# Tobolsk-A3JI-PP-Plant 500 kt/a (current) - EP Eng / Proc_DD 20110801

Schedule from Primavera P6, 2007-08-25 to 2013-06-11, data date 2011-09-01, costs in EUR, A marks actual dates.
110710 Bereinigung durch neue Kopie von EP/C mit den Baselines / 110709 Fehler nach Import / Update EP aus Dresden (Doppelte Relationships / !!) / 110118 Delete of Enginnering and Procurement Activities before merge to / Tobolsk-A3JI-PP-Plant 500 kt/a (current) / 110118 Tobolsk-A3JI-PP-Plant 500 kt/a (current) / Reflection-12.01.2011-KOPIE

## Calendars

- TB26 - 1 - Engineering: Mon-Fri 08:00-12:00, 13:00-17:00; Sat-Sun off. Exceptions (off unless hours are given): 2007-10-03, 2007-10-31, 2007-12-24 to 2007-12-26, 2007-12-31 to 2008-01-01, 2008-03-21, 2008-03-24, 2008-05-01, 2008-05-12, 2008-10-03, 2008-10-31, 2008-11-19, 2008-12-24 to 2008-12-26, 2008-12-31 to 2009-01-01, 2009-04-10, 2009-04-13, 2009-05-01, 2009-05-21, 2009-06-01, 2009-10-03, 2009-10-31, 2009-11-18, 2009-12-24 to 2009-12-26, 2009-12-31 to 2010-01-01, 2010-04-02, 2010-04-05, 2010-05-01, 2010-05-13, 2010-05-24, 2010-10-03, 2010-10-31, 2010-11-17, 2010-12-24 to 2010-12-26, 2010-12-31 to 2011-01-01, 2011-05-01, 2011-10-03, 2011-10-31, 2011-12-24 to 2011-12-26, 2011-12-31 to 2012-01-01, 2012-05-01, 2012-10-03, 2012-10-31, 2012-12-24 to 2012-12-26, 2012-12-31 to 2013-01-01, 2013-05-01.
- TB26 - 2 - Manuf and Delivy: Mon-Sun 08:00-12:00, 13:00-17:00. Exceptions (off unless hours are given): 2007-12-25 to 2007-12-26, 2008-01-01, 2008-05-01, 2008-12-25 to 2008-12-26, 2009-01-01, 2009-05-01, 2009-12-25 to 2009-12-26, 2010-01-01, 2010-05-01, 2010-12-25 to 2010-12-26, 2011-01-01, 2011-05-01, 2011-12-25 to 2011-12-26, 2012-01-01, 2012-05-01, 2012-12-25 to 2012-12-26, 2013-01-01, 2013-05-01.
- TB26 - 3 - Construct-normal *: Mon-Sat 08:00-12:00, 13:00-17:00; Sun off. Exceptions (off unless hours are given): 2007-12-25 to 2007-12-26, 2008-01-01, 2008-05-01, 2008-12-22 to 2009-01-10, 2009-01-12 to 2009-01-17, 2009-05-01, 2009-12-21 to 2009-12-26 08:00-16:00, 2009-12-27, 2009-12-28 to 2010-01-02 08:00-16:00, 2010-01-03, 2010-01-04 to 2010-01-09 08:00-16:00, 2010-01-10, 2010-01-11 to 2010-01-16 08:00-16:00, 2010-05-01, 2010-11-04, 2011-01-01, 2011-01-03 to 2011-01-08, 2011-02-23, 2011-03-08, 2011-05-02, 2011-05-09, 2011-06-13, 2011-11-04, 2012-01-01 to 2012-01-07, 2012-02-23, 2012-03-08, 2012-05-01, 2012-05-09, 2012-06-12, 2012-11-05, 2012-12-25 to 2012-12-26, 2013-01-01 to 2013-01-05, 2013-01-07, 2013-02-23, 2013-03-08, 2013-05-01, 2013-05-09.
- TB26 - S - Constr-Sumpf: Mon-Sat 08:00-12:00, 13:00-17:00; Sun off. Exceptions (off unless hours are given): 2007-12-25 to 2007-12-26, 2008-01-01, 2008-05-01, 2008-12-21 to 2009-01-17, 2009-03-02 to 2009-05-01, 2009-12-21 to 2010-01-16, 2010-03-01 to 2010-05-01, 2010-11-04, 2010-12-20 to 2011-01-15, 2011-02-23, 2011-03-01 to 2011-05-02, 2011-05-09, 2011-06-13, 2011-11-04, 2011-12-25 to 2011-12-26, 2012-01-01 to 2012-01-07, 2012-02-23, 2012-03-08, 2012-05-01, 2012-05-09, 2012-06-12, 2012-11-05, 2012-12-25 to 2012-12-26, 2013-01-01 to 2013-01-05, 2013-01-07, 2013-02-23, 2013-03-08, 2013-05-01, 2013-05-09.
- TB24 - 3 - Construct-normal: Mon-Sat 08:00-12:00, 13:00-17:00; Sun off. Exceptions (off unless hours are given): 2007-12-25 to 2007-12-26, 2008-01-01, 2008-05-01, 2008-12-22 to 2009-01-10, 2009-01-12 to 2009-01-17, 2009-05-01, 2009-12-21 to 2010-01-16, 2010-05-01, 2010-12-20 to 2011-01-01, 2011-01-03 to 2011-01-15, 2011-05-01, 2011-12-25 to 2011-12-26, 2012-01-01, 2012-12-25 to 2012-12-26, 2013-01-01, 2013-05-01.
- TB26 - 6 - Contract Milest.: Mon-Sun 08:00-12:00, 13:00-17:00. Exceptions (off unless hours are given): 2007-12-25 to 2007-12-26, 2008-01-01, 2008-05-01, 2008-12-25 to 2008-12-26, 2009-01-01, 2009-05-01, 2009-12-25 to 2009-12-26, 2010-05-01, 2010-11-04, 2010-12-25 to 2010-12-26, 2011-01-01, 2011-01-03 to 2011-01-08, 2011-01-17 to 2011-01-31, 2011-02-23, 2011-03-08, 2011-05-01 to 2011-05-02, 2011-05-09, 2011-06-13, 2011-11-04, 2011-12-25 to 2011-12-26, 2012-01-01 to 2012-01-08, 2012-02-23, 2012-03-08, 2012-05-01, 2012-05-09, 2012-06-12, 2012-11-05, 2012-12-25 to 2012-12-26, 2013-01-01 to 2013-01-07, 2013-02-23, 2013-03-08, 2013-05-01, 2013-05-09.
- TB26 - 2 - Manuf and Delivy-3: Mon-Sun 08:00-12:00, 13:00-17:00. Exceptions (off unless hours are given): 2007-12-25 to 2007-12-26, 2008-01-01, 2008-05-01, 2008-12-25 to 2008-12-26, 2009-01-01, 2009-05-01, 2009-12-25 to 2009-12-26, 2010-01-01, 2010-05-01, 2010-12-25 to 2010-12-26, 2011-01-01, 2011-05-01, 2011-12-25 to 2011-12-26, 2012-01-01, 2012-05-01, 2012-12-25 to 2012-12-26, 2013-01-01, 2013-05-01.
- TB24 - 2 - Manuf and Delivy: Mon-Sun 08:00-12:00, 13:00-17:00. Exceptions (off unless hours are given): 2007-12-25 to 2007-12-26, 2008-01-01, 2008-05-01, 2008-12-25 to 2008-12-26, 2009-01-01, 2009-05-01, 2009-12-25 to 2009-12-26, 2010-01-01, 2010-05-01, 2010-12-25 to 2010-12-26, 2011-01-01, 2011-05-01, 2011-12-25 to 2011-12-26, 2012-01-01, 2012-05-01, 2012-12-25 to 2012-12-26, 2013-01-01, 2013-05-01.

## Resources

| Resource | Group | Unit | Rate |
| --- | --- | --- | --- |
| Conveying S. piping field installation | material | Fpi | 150 |
| Control & Shut-off valves | material | pcs | 210 |
| Conveying system (Field) | labor |  |  |
| Install Control & Shut-off Valves | labor |  |  |
| Piperacks, Main Structures (Delivery) | material | t |  |
| Ladders & Platforms (Delivery) | material | t |  |
| TKB-S | labor |  |  |
| KM Drwgs preparation by Cheljabinsk | material | t |  |
| Static Equipment < 10 tons | material | t | 4000 |
| Static equipment < 10t | labor |  |  |
| TKB-B | labor |  |  |
| CP | labor |  |  |
| TAA | labor |  |  |
| TAP | labor |  |  |
| TAE | labor |  |  |
| TKK | labor |  |  |
| CB | labor |  |  |
| TKB-H | labor |  |  |
| TAS | labor |  |  |
| TME | labor |  |  |
| TAM | labor |  |  |
| TKR | labor |  |  |
| QM-Q | labor |  |  |

## Schedule

| ID | WBS | Activity | Type | Duration | Start | Finish | Predecessors | Complete | Total float | Free float | Calendar | Resources | Cost | UDF_SAVE ACTID | UDF_SAVE ACT ID | Department | Pro Unit/DocCode | Inquiry/Order No | PMT-Phase | PMT-Respons. | Zeigen/n. Zeigen | WBS Phase | WBS Discipline | WBS Type of Work | IMS | UPT | TB26 Ressource Budget | UDF_CONTRACT START DATE | UDF_CONTRACT FINISH DATE | UDF_CONTRACT ITEM | Type of Work | Constr. Area | PMT-Area | PMT-Schedule Org | WBS Objects | Russia WBS Discipline (Russia) | Russia Construction Area | Russia WBS Phase | Russia WBS Objects | UDF_CHECK CRITICAL PATH | UDF_CHECK BASELINE | PMT-Discipline | PMT-Stage |
| --- | --- | --- | --- | --- | --- | --- | --- | --- | --- | --- | --- | --- | --- | --- | --- | --- | --- | --- | --- | --- | --- | --- | --- | --- | --- | --- | --- | --- | --- | --- | --- | --- | --- | --- | --- | --- | --- | --- | --- | --- | --- | --- | --- |
| IMS-E-000010 |  | Process Design (last P&ID Issue CA14 Flare) | level of effort | 865d | 2007-12-10 A | 2011-05-19 A | F1640 SS, F4800 SS | 100% |  |  |  |  |  | IMS-E-000010 | IMS-E-000010 | 858 | 999 | 999 | E | LND | M1 | E | P | 0000 | 1 | IMS |  |  |  |  |  |  |  |  |  |  |  |  |  |  |  |  |  |
| IMS-E-000210 |  | Instrumentation Design | level of effort | 822d | 2007-12-10 A | 2011-03-21 A | F2170 SS | 100% |  |  |  |  |  | IMS-E-000210 | IMS-E-000210 | 86A | 999 |  | E | LND | M1 | E | J | EJ00 | I | IMS |  |  |  |  |  |  |  |  |  |  |  |  |  |  |  |  |  |
| XR40311005 |  | CA31 SiloStruc - Piping Installation (Conveying Piping) |  | 120d | 2011-09-17 | 2012-02-11 | XB50311010 (other project) FS-12d, XR203110 (other project) SS+60d |  | -1d | 80d | TB26 - 3 - Construct-normal * | Conveying S. piping field installation [3793 Fpi]; Control & Shut-off valves [13 pcs]; Conveying system (Field) [18965 h]; Install Control & Shut-off Valves [68 h] | 571,680 | XR40311005 | XR40311005 | 934 |  | 2DC8990 | C | LND |  | X | R | XR40 | PI | LND | 19033,00 | 2011-03-01 | 2012-01-30 | E-06-03-08 | ALL4 | 31 | 200 | 200 | 3110 | R | 31 | X | 3110 |  |  |  |  |
| XX0110 |  | PP Construction completion all Areas (LINDE) | milestone | 0d | 2012-10-20 | 2012-10-20 | XX0100 (other project) |  | 69d |  | TB26 - 6 - Contract Milest. |  |  | XX0110 | XX0110 |  |  |  | E | LND | L2 | X | 0B | 0000 | MC | LND |  |  |  |  |  | 0C | 200 | 200 | 0000 |  |  |  |  | HE00125 | x | 025 |  |
|  | 1 | **PROJECT A3JI** |  |  | 2007-08-25 | 2013-06-11 |  |  |  |  |  |  |  |  |  |  |  |  |  |  |  |  |  |  |  |  |  |  |  |  |  |  |  |  |  |  |  |  |  |  |  |  |  |
|  | PP | **Area PP** |  |  | 2007-08-25 | 2013-06-11 |  |  |  |  |  |  |  |  |  |  |  |  |  |  |  |  |  |  |  |  |  |  |  |  |  |  |  |  |  |  |  |  |  |  |  |  |  |
|  | 0 | **General** |  |  | 2007-12-10 | 2013-06-11 |  |  |  |  |  |  |  |  |  |  |  |  |  |  |  |  |  |  |  |  |  |  |  |  |  |  |  |  |  |  |  |  |  |  |  |  |  |
|  | 0E | **0E Engineering Milestones Disciplines** |  |  | 2007-12-10 | 2010-03-01 |  |  |  |  |  |  |  |  |  |  |  |  |  |  |  |  |  |  |  |  |  |  |  |  |  |  |  |  |  |  |  |  |  |  |  |  |  |
|  | LUZ2 | **LUZ2 General ( )** |  |  | 2007-12-10 | 2010-03-01 |  |  |  |  |  |  |  |  |  |  |  |  |  |  |  |  |  |  |  |  |  |  |  |  |  |  |  |  |  |  |  |  |  |  |  |  |  |
|  | 0A | **0A General Milestones** |  |  | 2007-12-10 | 2010-03-01 |  |  |  |  |  |  |  |  |  |  |  |  |  |  |  |  |  |  |  |  |  |  |  |  |  |  |  |  |  |  |  |  |  |  |  |  |  |
| F2760 |  | Effective Date of Contract (FEED) | milestone | 0d | 2007-12-10 A | 2007-12-10 A | F2110, F2220 | 100% |  |  |  |  |  | F2760 | F2760 | G |  |  | F |  | M1 | 0 | 0A | 0000 | 1 | LND |  |  |  |  |  | 0E | 200 | 001 | LUZ2 |  |  |  |  |  |  |  |  |
| F2790 |  | Issue 1st cost estimate (OBCE) for PMT approval | milestone | 0d | 2008-07-02 A | 2008-07-02 A | F2310 FF | 100% |  |  |  |  |  | F2790 | F2790 | G |  |  | F | LND | M1 | 0 | 0A | 0000 | 1 | LND |  |  |  |  |  | 0E | 200 | 001 | LUZ2 |  |  |  |  |  |  |  |  |
| F4065 |  | Final Blast Calculation (Vnipineft) | milestone | 0d | 2009-02-03 A | 2009-02-03 A | F2510, AD2230 FF-10d, F3060 | 100% |  |  |  |  |  | F4065 | F4065 | G |  |  | F | LND |  | 0 | 0A | 0000 |  | LND |  |  |  |  |  | 0E | 200 | 001 | LUZ2 |  |  |  |  |  |  | 002 | 3A |
| E3T150 |  | Issue 3rd cost estimate (OBCE) for PMT approval | milestone | 0d | 2009-08-17 A | 2009-08-17 A | F2790 | 100% |  |  |  |  |  | E3T150 | E3T150 | G |  |  | F | LND | M1 | 0 | 0A | 0000 | 1 | LND |  |  |  |  |  | 0E | 200 | 001 | LUZ2 |  |  |  |  |  |  |  |  |
| E3T155 |  | TEOC Documents approval | milestone | 0d | 2010-03-01 A | 2010-03-01 A | HE00090 SS | 100% |  |  |  |  |  | E3T155 | E3T155 | G |  |  | F | LND | M1 | 0 | 0A | 0000 | 1 | LND |  |  |  |  |  | 0E | 200 | 001 | LUZ2 |  |  |  |  |  |  |  |  |
|  | 0B | **0B General Activities** |  |  | 2008-02-18 | 2008-07-24 |  |  |  |  |  |  |  |  |  |  |  |  |  |  |  |  |  |  |  |  |  |  |  |  |  |  |  |  |  |  |  |  |  |  |  |  |  |
| F3350 |  | Commercial clarification |  | 110d | 2008-02-18 A | 2008-07-24 A | F3340 FF+2d | 100% |  |  |  |  |  | F3350 | F3350 | G |  |  | F | LND | 1 | 0 | 0B | 0000 | PI | LND |  |  |  |  |  | 0E | 200 |  | LUZ2 |  |  |  |  |  |  | 002 | 3A |
| F2340 |  | PDP Review Meeting Part I |  | 5d | 2008-02-20 A | 2008-02-26 A | F2760 | 100% |  |  |  |  |  | F2340 | F2340 | G |  |  | F | LND | 1 | 0 | 0B | 0000 | 1 | LND |  |  |  |  |  | 0E | 200 |  | LUZ2 |  |  |  |  |  |  | 002 | 3A |
|  | NO Obj | **No WBS Objects** |  |  | 2008-09-11 | 2009-04-01 |  |  |  |  |  |  |  |  |  |  |  |  |  |  |  |  |  |  |  |  |  |  |  |  |  |  |  |  |  |  |  |  |  |  |  |  |  |
|  | 0A | **0A General Milestones** |  |  | 2008-09-11 | 2009-04-01 |  |  |  |  |  |  |  |  |  |  |  |  |  |  |  |  |  |  |  |  |  |  |  |  |  |  |  |  |  |  |  |  |  |  |  |  |  |
| F3605 |  | Masterplotplan PDH/PP Plant confirmed PMT | milestone | 0d | 2008-09-11 A | 2008-09-11 A | F3600 FF | 100% |  |  |  |  |  | F3605 | F3605 | G |  |  |  | PMT | M1 | 0 | 0A | 0000 | PI | LND |  |  |  |  |  | 0E | 200 | 001 |  |  |  |  |  |  |  |  |  |
| F2765 |  | Standardisation Design finalized | milestone | 0d | 2008-10-01 A | 2008-10-01 A | F4210 FF, F4300 FF, F3950 FF, F4710 FF, F3670 FF, F4420 FF, F4190 FF | 100% |  |  |  |  |  | F2765 | F2765 | G |  |  |  | PMT | M1 | 0 | 0A | 0000 | 1 | LND |  |  |  |  |  | 0E |  |  |  |  |  |  |  |  |  |  |  |
| F2767 |  | Decissions Value Awaren./Cost Savings completed | milestone | 0d | 2008-10-31 A | 2008-10-31 A | F2310, F2765 FS+20d | 100% |  |  |  |  |  | F2767 | F2767 | G |  |  |  | PMT | M1 | 0 | 0A | 0000 | 1 | LND |  |  |  |  |  | 0E |  |  |  |  |  |  |  |  |  |  |  |
| M3C110 |  | Final Soil Invest./Piling Load Test available | milestone | 0d | 2009-04-01 A | 2009-04-01 A | EC15000005 FF | 100% |  |  | TB26 - 3 - Construct-normal * |  |  | M3C110 | M3C110 | 934 |  |  |  | PMT | M1 | 0 | 0A |  | E | LND |  |  |  |  |  | 0E |  |  |  |  |  |  |  |  |  |  |  |

Notes:
- IMS-E-000010: UDF_Actictity Name (Russia): Проектирование технологической части
- IMS-E-000210: UDF_Actictity Name (Russia): Проектирование КИП
- XX0110: UDF_Actictity Name (Russia): Завершение механических работ на всех участках ПП (обязательно)
- F2760: UDF_Actictity Name (Russia): Дата вступления контракта в силу (FEED)
- F2790: UDF_Actictity Name (Russia): Выпуск 1ой сметы (OBCE) для утверждения PMT
- E3T150: UDF_Actictity Name (Russia): Выпуск 3ей сметы (OBCE) для утверждения PMT
- E3T155: UDF_Actictity Name (Russia): Одобрение документов ТЭОС
- F3605: UDF_Actictity Name (Russia): Генплан установки ДГП/ПП подтвержден PMT
- F2765: UDF_Actictity Name (Russia): Завершение стандартизации проектирования
- F2767: UDF_Actictity Name (Russia): Принятие решений по повышению эффективности/экономии затрат
- M3C110: UDF_Actictity Name (Russia): Окончательное исследование грунта/испытание свай нагрузкой

| ID | WBS | Activity | Type | Duration | Start | Finish | Predecessors | Complete | Total float | Free float | Constraint | Calendar | UDF_SAVE ACTID | UDF_SAVE ACT ID | Department | Constr. Area | Pro Unit/DocCode | PMT-Area | PMT-Schedule Org | PMT-Phase | PMT-Respons. | Zeigen/n. Zeigen | WBS Phase | WBS Discipline | WBS Type of Work | WBS Objects | Russia WBS Discipline (Russia) | Russia Construction Area | Russia WBS Phase | IMS | UPT | PMT-Discipline | UDF_CHECK CRITICAL PATH |
| --- | --- | --- | --- | --- | --- | --- | --- | --- | --- | --- | --- | --- | --- | --- | --- | --- | --- | --- | --- | --- | --- | --- | --- | --- | --- | --- | --- | --- | --- | --- | --- | --- | --- |
|  | 00 | **00 Construction Areas - General** |  |  | 2009-02-03 | 2013-06-11 |  |  |  |  |  |  |  |  |  |  |  |  |  |  |  |  |  |  |  |  |  |  |  |  |  |  |  |
|  | LUTZ | **LUTZ Construction General** |  |  | 2012-08-08 | 2012-08-08 |  |  |  |  |  |  |  |  |  |  |  |  |  |  |  |  |  |  |  |  |  |  |  |  |  |  |  |
|  | 0A | **0A General Milestones** |  |  | 2012-08-08 | 2012-08-08 |  |  |  |  |  |  |  |  |  |  |  |  |  |  |  |  |  |  |  |  |  |  |  |  |  |  |  |
| X3E120 |  | Delivery Power Supply / Energizing Substation | milestone | 0d | 2012-08-08 | 2012-08-08 | XE600C10 (other project) FF |  | -61.5d | 0d |  | TB26 - 3 - Construct-normal * | X3E120 | X3E120 | 934 | 00 | 91 | 200 | 200 | C | PMT | M1 | 0 | 0A | XE00 | LUTZ | E | 00 | X | C | OWN |  |  |
|  | 0000 | **0000 Generals - all CA's** |  |  | 2009-02-03 | 2013-06-11 |  |  |  |  |  |  |  |  |  |  |  |  |  |  |  |  |  |  |  |  |  |  |  |  |  |  |  |
|  | 0A | **0A General Milestones** |  |  | 2012-07-26 | 2013-06-11 |  |  |  |  |  |  |  |  |  |  |  |  |  |  |  |  |  |  |  |  |  |  |  |  |  |  |  |
| HE00200 |  | Project Float |  | 37d | 2012-07-26 | 2012-08-31 | HE00125 |  | 0d |  | mandatory finish 2012-08-31 | TB26 - 6 - Contract Milest. | HE00125 | HE00200 |  | 00 |  | 200 | 200 | E | PMT | L2 | 0 | 0A | 0000 | 0000 |  |  |  | MC | LND | 025 |  |
| HE00125 |  | PP Construction completion all Areas | milestone | 0d | 2012-10-20 | 2012-10-20 | IMS-LND-MC-00020 |  | -86.5d | 0d |  | TB26 - 6 - Contract Milest. | HE00125 | HE00125 |  | 00 |  | 200 | 200 | E | LND | L2 | 0 | 0A | 0000 | 0000 |  |  |  | MC | LND | 025 | HE00125 |
| HE00160 |  | Plant Acceptance | milestone | 0d | 2013-06-11 | 2013-06-11 | HE00150 FF |  | 0d |  |  | TB26 - 3 - Construct-normal * | HE00160 | HE00160 |  | 00 |  | 200 | 200 | E | LND | L2 | 0 | 0A | 0000 | 0000 |  |  |  | SU | OWN | 025 |  |
|  | 0B | **0B General Activities** |  |  | 2009-02-03 | 2013-06-11 |  |  |  |  |  |  |  |  |  |  |  |  |  |  |  |  |  |  |  |  |  |  |  |  |  |  |  |
| F4060 |  | Final Plant Layout Freeze | milestone | 0d | 2009-02-03 A | 2009-02-03 A | AD2230 FF, F2510 FF+1d, F3060 FF | 100% |  |  |  |  | F4060 | F4060 |  | 00 |  | 200 | 001 | F | LND | L2 | 0 | 0B | 0000 | 0000 |  |  |  |  | LND | 002 |  |
| HE00092 |  | Preliminary GEOTECH Report issued | milestone | 0d | 2009-03-31 A | 2009-03-31 A | F4880 | 100% |  |  |  | TB26 - 2 - Manuf and Delivy | HE00092 | HE00092 |  | 00 |  | 200 | 200 | E | LND | L2 | 0 | 0B | 0000 | 0000 |  |  |  | ML | OWN | 025 |  |
| HE00035 |  | Contract in place for Detail Engineering | milestone | 0d | 2009-04-30 A | 2009-04-30 A |  | 100% |  |  |  |  | HE00035 | HE00035 |  | 00 |  | 200 | 200 | E | LND | L2 | 0 | 0B | 0000 | 0000 |  |  |  | ML | LND | 025 |  |
| HE00100 |  | TEOC Documents complete for submittal | milestone | 0d | 2009-06-02 A | 2009-06-02 A | HE00090 SF-90d | 100% |  |  |  |  | HE00100 | HE00100 |  | 00 |  | 200 | 200 | E | LND | L2 | 0 | 0B | 0000 | 0000 |  |  |  | ML | OWN | 025 |  |
| HE00094 |  | Final GEOTECH Report issued | milestone | 0d | 2009-06-04 A | 2009-06-04 A | HE00092 | 100% |  |  |  | TB26 - 2 - Manuf and Delivy | HE00094 | HE00094 |  | 00 |  | 200 | 200 | E | LND | L2 | 0 | 0B | 0000 | 0000 |  |  |  | ML | OWN | 025 |  |
| HE00050 |  | Start Excavation / Piling | milestone | 0d | 2009-11-07 A | 2009-11-07 A | XC150C0010 (other project) SS | 100% |  |  |  | TB26 - 2 - Manuf and Delivy | HE00050 | HE00050 |  | 00 |  | 200 | 200 | E | LND | L2 | 0 | 0B | 0000 | 0000 |  |  |  | P | LND | 025 |  |
| HE00090 |  | TEOC approval | milestone | 0d | 2010-03-01 A | 2010-03-01 A |  | 100% |  |  |  | TB26 - 2 - Manuf and Delivy | HE00090 | HE00090 |  | 00 |  | 200 | 200 | E | LND | L2 | 0 | 0B | 0000 | 0000 |  |  |  | ML | OWN | 025 |  |
| HE00040 |  | 1st PO Award Structural Steel | milestone | 0d | 2010-06-01 A | 2010-06-01 A | P3N01D | 100% |  |  |  | TB26 - 2 - Manuf and Delivy | HE00040 | HE00040 |  | 00 |  | 200 | 200 | E | LND | L2 | 0 | 0B | 0000 | 0000 |  |  |  | P | LND | 025 |  |
| HE00070 |  | 1st Issue AG ISO's for Construction | milestone | 0d | 2010-08-23 A | 2010-08-23 A | ER493110, ER495401 SS, ER495102 SS, ER495103 SS | 100% |  |  |  | TB26 - 2 - Manuf and Delivy | HE00070 | HE00070 |  | 00 |  | 200 | 200 | E | LND | L2 | 0 | 0B | 0000 | 0000 |  |  |  | 5 | LND | 025 |  |
| HE00060 |  | 1st Delivery at Site Structural Steel | milestone | 0d | 2010-12-06 A | 2010-12-06 A | HE00040 SS, P3N02BN | 100% |  |  |  | TB26 - 2 - Manuf and Delivy | HE00060 | HE00060 |  | 00 |  | 200 | 200 | E | LND | L2 | 0 | 0B | 0000 | 0000 |  |  |  | SS | LND | 025 |  |
| HE00080 |  | Last Issue AG ISO's for Construction | milestone | 0d | 2011-04-11 A | 2011-04-11 A | ER491730 FF, ER491760 FF, ER491740 FF | 100% |  |  |  | TB26 - 2 - Manuf and Delivy | HE00080 | HE00080 |  | 00 |  | 200 | 200 | E | LND | L2 | 0 | 0B | 0000 | 0000 |  |  |  | 5 | LND | 025 |  |
| HE00110 |  | Final MTO Piping Material | milestone | 0d | 2011-04-11 A | 2011-04-11 A | A1KL1137 FF | 100% |  |  |  | TB26 - 2 - Manuf and Delivy | HE00110 | HE00110 |  | 00 |  | 200 | 200 | E | LND | L2 | 0 | 0B | 0000 | 0000 |  |  |  | 1 | LND | 025 |  |
| HE00130 |  | Pre-Commissioning complete post MC activities |  | 50d | 2012-12-31 | 2013-03-07 | XX0100 (other project), XX120 (other project), YY0110 (other project) SS, XX0110, HE00125 |  | 79d |  |  | TB26 - 3 - Construct-normal * | HE00130 | HE00130 |  | 00 |  | 200 | 200 | E | LND | L2 | 0 | 0B | 0000 | 0000 |  |  |  | CM | OWN | 025 |  |
| HE00135 |  | Commissioning by Owner |  | 78d | 2012-12-31 | 2013-04-10 | HE00125, XX0100 (other project), XX0110, IMS-LND-MC-00010 |  | 0d |  |  | TB26 - 3 - Construct-normal * | HE00135 | HE00135 |  | 00 |  | 200 | 200 | E | OWN | L2 | 0 | 0B | 0000 | 0000 |  |  |  | CM | OWN | 025 | XX120 |
| HE00140 |  | Ready for Startup | milestone | 0d | 2013-04-11 | 2013-04-11 | HE00135 FF+1d |  | 0d |  |  | TB26 - 2 - Manuf and Delivy | HE00140 | HE00140 |  | 00 |  | 200 | 200 | E | LND | L2 | 0 | 0B | 0000 | 0000 |  |  |  | SU | OWN | 025 |  |
| HE00150 |  | Performance Test |  | 60d | 2013-04-11 | 2013-06-11 | HE00140 |  | 0d |  |  | TB26 - 2 - Manuf and Delivy | HE00150 | HE00150 |  | 00 |  | 200 | 200 | E | LND | L2 | 0 | 0B | 0000 | 0000 |  |  |  | SU | OWN | 025 |  |

Notes:
- X3E120: UDF_Actictity Name (Russia): Поставка подстанции электроснабжения
- HE00200: UDF_Actictity Name (Russia): Завершение механических работ на всех участках ПП (обязательно)
- HE00125: UDF_Actictity Name (Russia): Завершение механических работ на всех участках ПП (обязательно)
- HE00160: UDF_Actictity Name (Russia): Приемо-сдача Установки
- F4060: UDF_Actictity Name (Russia): Утверждение окончательного плана Установки
- HE00092: UDF_Actictity Name (Russia): Выпуск предварительного геотехнического отчета
- HE00035: UDF_Actictity Name (Russia): Выпуск предварительного геотехнического отчета
- HE00100: UDF_Actictity Name (Russia): Документы TEOC, готовые для передачи
- HE00094: UDF_Actictity Name (Russia): Выпуск окончательного геотехнического отчета
- HE00050: UDF_Actictity Name (Russia): Начало экскавационных / сваезабивных работ
- HE00090: UDF_Actictity Name (Russia): Утверждение TEOC
- HE00040: UDF_Actictity Name (Russia): 1-й заказ на поставку металлоконструкций
- HE00070: UDF_Actictity Name (Russia): Начало экскавационных / сваезабивных работ
- HE00060: UDF_Actictity Name (Russia): 1-я поставка на площадку металлоконструкций
- HE00080: UDF_Actictity Name (Russia): Последний выпуск изометрических чертежей надземных конструкций для строительства
- HE00110: UDF_Actictity Name (Russia): Окончательные MTO на материалы трубопроводов
- HE00130: UDF_Actictity Name (Russia): Завершение пуско-наладки и готовность к запуску
- HE00135: UDF_Actictity Name (Russia): Завершение пуско-наладки и готовность к запуску
- HE00140: UDF_Actictity Name (Russia): Запуск Установки
- HE00150: UDF_Actictity Name (Russia): Пробрый прогон на подтверждение гарантированных характеристик

| ID | WBS | Activity | Type | Duration | Start | Finish | Predecessors | Complete | Total float | Free float | Constraint | Calendar | UDF_SAVE ACTID | UDF_SAVE ACT ID | PMT-Area | PMT-Schedule Org | PMT-Discipline | PMT-Phase | PMT-Respons. | Zeigen/n. Zeigen | WBS Phase | WBS Discipline | WBS Type of Work | WBS Objects | IMS | UPT | Department | Constr. Area | Comments | UDF_CHECK CRITICAL PATH | UDF_CHECK BASELINE | PMT-Stage |
| --- | --- | --- | --- | --- | --- | --- | --- | --- | --- | --- | --- | --- | --- | --- | --- | --- | --- | --- | --- | --- | --- | --- | --- | --- | --- | --- | --- | --- | --- | --- | --- | --- |
|  | NO CA | **No Constr. Area** |  |  | 2007-12-10 | 2013-04-11 |  |  |  |  |  |  |  |  |  |  |  |  |  |  |  |  |  |  |  |  |  |  |  |  |  |  |
|  | 0000 | **0000 Generals - all CA's** |  |  | 2010-07-14 | 2010-08-18 |  |  |  |  |  |  |  |  |  |  |  |  |  |  |  |  |  |  |  |  |  |  |  |  |  |  |
|  | 0B | **0B General Activities** |  |  | 2010-07-14 | 2010-08-18 |  |  |  |  |  |  |  |  |  |  |  |  |  |  |  |  |  |  |  |  |  |  |  |  |  |  |
| HE00020 |  | Period River Shipment Reactor's/Purge Columns | level of effort | 36d | 2010-07-14 A | 2010-08-18 A | P3ALL2N3 SS, P3ALL1N3 SS, P3ALL2N3 FF, P3ALL1N3 FF | 100% |  |  |  | TB26 - 2 - Manuf and Delivy | HE00020 | HE00020 | 200 | 200 | 025 | E | LND | L2 | 0 | 0B | 0000 | 0000 | E | LND |  |  |  |  |  |  |
|  | NO Obj | **No WBS Objects** |  |  | 2007-12-10 | 2013-04-11 |  |  |  |  |  |  |  |  |  |  |  |  |  |  |  |  |  |  |  |  |  |  |  |  |  |  |
|  | 0A | **0A General Milestones** |  |  | 2011-10-14 | 2013-04-11 |  |  |  |  |  |  |  |  |  |  |  |  |  |  |  |  |  |  |  |  |  |  |  |  |  |  |
| P3B190 |  | LLE Equipment Delivery Completion (PRU) | milestone | 0d | 2011-10-14 | 2011-10-14 | P3U12S FF |  | 597.5d |  |  | TB24 - 2 - Manuf and Delivy | P3B190 | P3B190 |  |  |  | E | LND | M1 | 0 | 0A |  |  | E | LND | 007 | 00 |  |  |  |  |
| IMS-LND-MC-00020 |  | Construction Completion all Areas PP-Plant | milestone | 0d | 2012-10-20 | 2012-10-20 | XX0100 (other project) |  | -95.5d | 0d | finish on or before 2012-06-30 | TB26 - 3 - Construct-normal * | IMS-LND-MC-00010 | IMS-LND-MC-00020 |  |  |  | E | LND | M1 | 0 | 0A |  |  | MC | IMS | 007 |  | Set Constraint 30.6.12 | HE00125 |  |  |
| IMS-LND-MC-00030 |  | Remaining Punch List (Linde) | level of effort | 58d | 2012-10-20 | 2012-12-31 | IMS-LND-MC-00020 |  | -67.5d | 0d |  | TB26 - 3 - Construct-normal * | IMS-LND-MC-00010 | IMS-LND-MC-00030 |  |  |  | E | LND |  | 0 | 0A |  |  | MC | IMS | 007 | 00 | Set Constraint 30.6.12 |  |  |  |
| IMS-LND-MC-00010 |  | Mechanical Completion all Areas (Target) | milestone | 0d | 2012-12-31 | 2012-12-31 | XX120 (other project), IMS-LND-MC-00030 |  | -67.5d | 0d |  | TB26 - 3 - Construct-normal * | IMS-LND-MC-00010 | IMS-LND-MC-00010 |  |  |  | E | LND | M1 | 0 | 0A |  |  | MC | IMS | 007 | 00 |  | XX120 |  |  |
| IMS-LND-MC-00015 |  | Mechanical Completion all Areas (Contract) | milestone | 0d | 2012-12-31 | 2012-12-31 | IMS-LND-MC-00010, XX120 (other project) |  | -67.5d | 129d | finish on 2012-10-09 | TB26 - 3 - Construct-normal * | IMS-LND-MC-00015 | IMS-LND-MC-00015 |  |  |  | E | LND | M1 | 0 | 0A |  |  | MC | IMS | 007 | 00 |  | XX120 |  |  |
| XX0120 |  | Ready Plant StartUp | milestone | 0d | 2013-04-11 | 2013-04-11 | HE00140 FF, XX0100 (other project) FF, XX120 (other project), YY0110 (other project), X0300035 (other project) |  | 51d |  |  | TB24 - 3 - Construct-normal | XX0120 | XX0120 |  |  |  | E | LND | M1 | 0 | 0A |  |  | SU | OWN | 007 | 00 |  |  | x |  |
|  | 0B | **0B General Activities** |  |  | 2007-12-10 | 2011-04-25 |  |  |  |  |  |  |  |  |  |  |  |  |  |  |  |  |  |  |  |  |  |  |  |  |  |  |
| M3T100 |  | FEED Phase | level of effort | 224d | 2007-12-10 A | 2008-10-30 A | F2760 SS, F2670 FF | 100% |  |  |  |  | M3T100 | M3T100 |  |  |  | E | LND | M1 | 0 | 0B |  |  | ML | LND | 007 |  |  |  |  |  |
| M3C100 |  | Site Survey / Soil Investigation Report | level of effort | 209d | 2008-06-02 A | 2009-03-31 A | EC15000005 SS | 100% |  |  |  |  | M3C100 | M3C100 |  |  |  | E | PMT | M1 | 0 | 0B |  |  | E | LND | G |  |  |  |  |  |
| M3T110 |  | Advanced Detail Phase | level of effort | 127d | 2008-06-02 A | 2008-11-28 A | F8880 FF, F1550 FF, F4340 FF, AD1800 FF, AD1810 FF, AD2120 FF, AD2220 FF, F3360 FF, F3605 FF, F3850 FF, F4180 FF, F8780 FF, F3910 FF, F3830 FF, F1480 FF, RF1030 FF, AD1700 FF, AD2100 FF, AD5500, F3880 FF, F4790 FF, F3860 FF, AD1200 SS, AD0100 FF, AD0180 FF, RF1010 FF, AD2110 FF, F8720 FF, F2340 FF, F1280 FF, F2960 FF, F1720 FF, F3260 SF, F1630 FF, F1690 FF, F3050 FF, AD2010 FF, AD2030 FF, F2120 FF, F4390, F3750 FF, F1060 FF, AD1920 FF, RF1040 FF, AD1110 FF, AD1880 FF, AD1820 FF, AD1840 FF, AD1620 FF, F1800 FF, F4240 FF, F8870 FF, F2300, F4780 FF, AD1210 FF, AD1630 FF, F2700 FF, F2950 FF, F2190 FF, F2200 FF, HPB20 FF, F4820 FF, F3400 FF, F1460 FF, F4310 FF, F3900 FF, F3840 FF, F1420, AD1150 FF, AD1320 FF, F2767 FF, F4280 FF, F8850 FF, F1300 FF, F3800 FF, AD1000 FF, RF1000 FF, AD1910 FF, RF1020 FF, AD5000 FF, AD0150 FF, AD1090 FF, AD1610 FF, AD1730 FF, F4700 FF, F2210 FF | 100% |  |  |  |  | M3T110 | M3T110 |  |  |  | E | LND | M1 | 0 | 0B |  |  | ML | LND | 007 |  |  |  |  |  |
| M3T120 |  | Detail Engineering Part I (Ext. Phase) |  | 101d | 2008-11-03 A | 2009-03-31 A | A1CF0235 SS | 100% |  |  |  |  | M3T120 | M3T120 |  |  |  | E | LND | M1 | 0 | 0B |  |  | ML | LND | 007 |  |  |  |  |  |
| M3T140 |  | Detail Engineering Part II | level of effort | 520d | 2009-04-03 A | 2011-04-25 A | F3080 SS | 100% |  |  |  |  | M3T140 | M3T140 |  |  |  | E | LND | M1 | 0 | 0B |  |  | 00 | LND | 007 |  |  |  |  |  |
|  | E | **Engineering** |  |  | 2007-08-25 | 2011-12-13 |  |  |  |  |  |  |  |  |  |  |  |  |  |  |  |  |  |  |  |  |  |  |  |  |  |  |
|  | 0E | **0E Engineering Milestones Disciplines** |  |  | 2007-08-25 | 2011-04-15 |  |  |  |  |  |  |  |  |  |  |  |  |  |  |  |  |  |  |  |  |  |  |  |  |  |  |
|  | 0000 | **0000 Generals - all CA's** |  |  | 2008-09-18 | 2010-09-03 |  |  |  |  |  |  |  |  |  |  |  |  |  |  |  |  |  |  |  |  |  |  |  |  |  |  |
|  | E | **E Electrical** |  |  | 2008-09-18 | 2008-09-18 |  |  |  |  |  |  |  |  |  |  |  |  |  |  |  |  |  |  |  |  |  |  |  |  |  |  |
| AD2040 |  | PUE/IEC utilization cable trays | milestone | 0d | 2008-09-18 A | 2008-09-18 A | F3920 FF | 100% |  |  |  |  | AD2040 | AD2040 | 200 | 001 | 001 | F | PMT | 1 | E | E | EE00 | 0000 | INS | LND | 874 | 0E |  |  |  | 3A |
|  | T | **T Turnover Engineering** |  |  | 2010-05-03 | 2010-09-03 |  |  |  |  |  |  |  |  |  |  |  |  |  |  |  |  |  |  |  |  |  |  |  |  |  |  |
| ETMS0110 |  | Turnover structure approved by PMT/Sibur | milestone | 0d | 2010-05-03 A | 2010-05-03 A | ET000100 FF | 100% |  |  |  |  | ETMS0110 | ETMS0110 | 200 | 200 | 002 | E | PMT | 1 | E | T | 0000 | 0000 | 00 | LND | 934 | 0E |  |  |  | 3B |
| ETMS0100 |  | Turnover procedure approved by PMT/Sibur | milestone | 0d | 2010-09-03 A | 2010-09-03 A | ET000120 FF+10d | 100% |  |  |  |  | ETMS0100 | ETMS0100 | 200 | 200 | 002 | E | PMT | 1 | E | T | 0000 | 0000 | 00 | LND | 934 | 0E |  |  |  | 3B |

Notes:
- HE00020: UDF_Actictity Name (Russia): Этап транспортировки речным транспортом реакторов/продувочных колонн
- P3B190: UDF_Actictity Name (Russia): Завершение поставки оборудования с долгим сроком поставки (PRU)
- IMS-LND-MC-00020: UDF_Actictity Name (Russia): Завершение механических работ на всех участках
- IMS-LND-MC-00030: UDF_Actictity Name (Russia): Завершение механических работ на всех участках
- IMS-LND-MC-00010: UDF_Actictity Name (Russia): Завершение механических работ на всех участках
- IMS-LND-MC-00015: UDF_Actictity Name (Russia): Завершение механических работ на всех участках
- XX0120: UDF_Actictity Name (Russia): Готовность к запуску
- M3T100: UDF_Actictity Name (Russia): Стадия FEED
- M3C100: UDF_Actictity Name (Russia): Отчет о инженерно-геологических изысканиях/исследовании грунта
- M3T110: UDF_Actictity Name (Russia): Стадия "Проект"
- M3T120: UDF_Actictity Name (Russia): Детальное проектирование, Часть I (нар. стадия)
- M3T140: UDF_Actictity Name (Russia): Детальное проектирование, Часть II

| ID | WBS | Activity | Type | Duration | Start | Finish | Predecessors | Complete | UDF_SAVE ACTID | UDF_SAVE ACT ID | Department | Constr. Area | PMT-Area | PMT-Phase | PMT-Stage | PMT-Respons. | Zeigen/n. Zeigen | WBS Phase | WBS Discipline | WBS Type of Work | WBS Objects | IMS | UPT | PMT-Schedule Org | PMT-Discipline | Type of Work | Inquiry/Order No |
| --- | --- | --- | --- | --- | --- | --- | --- | --- | --- | --- | --- | --- | --- | --- | --- | --- | --- | --- | --- | --- | --- | --- | --- | --- | --- | --- | --- |
|  | LUZ2 | **LUZ2 General ( )** |  |  | 2007-08-25 | 2011-04-15 |  |  |  |  |  |  |  |  |  |  |  |  |  |  |  |  |  |  |  |  |  |
|  | 0B | **0B General Activities** |  |  | 2007-08-25 | 2011-04-15 |  |  |  |  |  |  |  |  |  |  |  |  |  |  |  |  |  |  |  |  |  |
| F2100 |  | Blanked out PDP | milestone | 0d | 2007-08-25 A | 2007-08-25 A |  | 100% | F2100 | F2100 | I | 0E | 200 | F | 3A | INE | 1 | E | 0B | 0000 | LUZ2 | 1 | LND |  |  |  |  |
| F2150 |  | Spec. Extruder Package | milestone | 0d | 2007-09-12 A | 2007-09-12 A | F2100 | 100% | F2150 | F2150 | I | 0E | 200 | F | 3A | INE | 1 | E | 0B | 0000 | LUZ2 | 1 | LND |  |  |  |  |
| F2160 |  | Spec. 1st Reactor Package | milestone | 0d | 2007-09-12 A | 2007-09-12 A | F2100 | 100% | F2160 | F2160 | I | 0E | 200 | F | 3A | INE | 1 | E | 0B | 0000 | LUZ2 | 1 | LND |  |  |  |  |
| F2180 |  | Spec.Reciprocating Compressor PDS ->C-301 | milestone | 0d | 2007-09-12 A | 2007-09-12 A | F2100 | 100% | F2180 | F2180 | I | 0E | 200 | F | 3A | INE | 1 | E | 0B | 0000 | LUZ2 | 1 | LND |  |  |  |  |
| F2280 |  | Spec.Sundyne Compressor PDS ->C-201 | milestone | 0d | 2007-09-12 A | 2007-09-12 A | F2100 | 100% | F2280 | F2280 | I | 0E | 200 | F | 3A | INE | 1 | E | 0B | 0000 | LUZ2 | 1 | LND |  |  |  |  |
| F4710 |  | Standardization Program Development |  | 204d | 2007-12-07 A | 2008-09-30 A | F3480, M3T100 FF | 100% | F4710 | F4710 | L2 | 0E | 200 | F |  |  |  | E | 0B | 0000 | LUZ2 |  | LND | 001 | 001 |  |  |
| F2110 |  | Rev A PFD Release | milestone | 0d | 2007-12-08 A | 2007-12-08 A | F2100 | 100% | F2110 | F2110 | I | 0E | 200 | F | 3A | INE | 1 | E | 0B | 0000 | LUZ2 | 1 | LND |  |  |  |  |
| F2220 |  | Plotplan | milestone | 0d | 2007-12-08 A | 2007-12-08 A | F2100 | 100% | F2220 | F2220 | I | 0E | 200 | F | 3A | INE | 1 | E | 0B | 0000 | LUZ2 | 1 | LND |  |  |  |  |
| F2120 |  | Rev A Equipment List - Licensor | milestone | 0d | 2007-12-21 A | 2007-12-21 A | F2100 | 100% | F2120 | F2120 | L | 0E | 200 | F | 3A | INE | 1 | E | 0B | 0000 | LUZ2 | 1 | LND |  |  |  |  |
| F4670 |  | LOI award | milestone | 0d | 2007-12-21 A | 2007-12-21 A | F2760 | 100% | F4670 | F4670 | G | 0E | 200 | F | 3A | PMT | 1 | E | 0B | 0000 | LUZ2 |  | LND | 001 | 002 |  |  |
| F2350 |  | Issue Heat & Material Balances | milestone | 0d | 2008-01-04 A | 2008-01-04 A | F2100 | 100% | F2350 | F2350 | I | 0E | 200 | F | 3A | INE | 1 | E | 0B | 0000 | LUZ2 | 1 | LND |  |  |  |  |
| F2230 |  | Rev XA P&ID Electronic Release | milestone | 0d | 2008-01-08 A | 2008-01-08 A | F2100 | 100% | F2230 | F2230 | I | 0E | 200 | F | 3A | INE | 1 | E | 0B | 0000 | LUZ2 | 1 | LND |  |  |  |  |
| F2360 |  | Issue Utility Balances | milestone | 0d | 2008-01-08 A | 2008-01-08 A | F2100 | 100% | F2360 | F2360 | I | 0E | 200 | F | 3A | INE | 1 | E | 0B | 0000 | LUZ2 | 1 | LND |  |  |  |  |
| F2680 |  | Long Lead Equipment List - PMT | milestone | 0d | 2008-01-12 A | 2008-01-12 A | F2760 | 100% | F2680 | F2680 | L3 | 0E | 200 | F | 3A | PMT | 1 | E | 0B | 0000 | LUZ2 | 1 | LND | 001 |  |  |  |
| F2700 |  | Equipment Spec's PU Propylene Rec.Unit- Licensor | milestone | 0d | 2008-01-18 A | 2008-01-18 A | F2100 | 100% | F2700 | F2700 | L | 0E | 200 | F | 3A | INE | 1 | E | 0B | 0000 | LUZ2 | 1 | LND |  |  |  |  |
| F4320 |  | Standardization Mechanical eng./design standards | milestone | 0d | 2008-01-26 A | 2008-01-26 A | F2760 | 100% | F4320 | F4320 | L2 | 0E | 200 | F | 3A | PMT | 1 | E | 0B | 0000 | LUZ2 |  | LND | 001 |  |  |  |
| F2140 |  | Rev 0 PFD Release with PDP | milestone | 0d | 2008-01-30 A | 2008-01-30 A | F2100 | 100% | F2140 | F2140 | I | 0E | 200 | F | 3A | INE | 1 | E | 0B | 0000 | LUZ2 | 1 | LND |  |  |  |  |
| F2190 |  | Major Equipment Spec's - Vessels - Licensor | milestone | 0d | 2008-01-30 A | 2008-01-30 A | F2100 | 100% | F2190 | F2190 | L | 0E | 200 | F | 3A | INE | 1 | E | 0B | 0000 | LUZ2 | 1 | LND |  |  |  |  |
| F2200 |  | Major Equipment Spec's - Exchanger - Licensor | milestone | 0d | 2008-01-30 A | 2008-01-30 A | F2100 | 100% | F2200 | F2200 | L | 0E | 200 | F | 3A | INE | 1 | E | 0B | 0000 | LUZ2 | 1 | LND |  |  |  |  |
| F2210 |  | Major Equipment Spec's - Rot. Equipment - Licens | milestone | 0d | 2008-01-30 A | 2008-01-30 A | F2100 | 100% | F2210 | F2210 | L | 0E | 200 | F | 3A | INE | 1 | E | 0B | 0000 | LUZ2 | 1 | LND |  |  |  |  |
| F2240 |  | Rev 0 P&ID Electronic Release native files | milestone | 0d | 2008-01-30 A | 2008-01-30 A | F2100 | 100% | F2240 | F2240 | I | 0E | 200 | F | 3A | INE | 1 | E | 0B | 0000 | LUZ2 | 1 | LND |  |  |  |  |
| F2260 |  | PDP Release | milestone | 0d | 2008-01-30 A | 2008-01-30 A | F2100 | 100% | F2260 | F2260 | I | 0E | 200 | F | 3A | INE | 1 | E | 0B | 0000 | LUZ2 | 1 | LND |  |  |  |  |
| F2710 |  | Process Data Sheets all Equipment - Licensor | milestone | 0d | 2008-01-30 A | 2008-01-30 A | F2100 | 100% | F2710 | F2710 | L | 0E | 200 | F | 3A | INE | 1 | E | 0B | 0000 | LUZ2 | 1 | LND |  |  |  |  |
| F3370 |  | Stepwise Handover of PDP completed | milestone | 0d | 2008-01-30 A | 2008-01-30 A | F4670 | 100% | F3370 | F3370 | G | 0E | 200 | F |  | INE |  | E | 0B | 0000 | LUZ2 | PI | LND | 001 |  |  |  |
| F3510 |  | Process Description (part of PDP)-Licensor | milestone | 0d | 2008-01-30 A | 2008-01-30 A | F2100 | 100% | F3510 | F3510 | L3 | 0E | 200 | F | 3A | INE | 1 | E | 0B | 0000 | LUZ2 | PI | LND | 001 |  |  |  |
| F3520 |  | PFD-electronic release -Licensor | milestone | 0d | 2008-01-30 A | 2008-01-30 A | F2230 FF | 100% | F3520 | F3520 | L3 | 0E | 200 | F | 3A | INE | 1 | E | 0B | 0000 | LUZ2 | PI | LND | 001 |  |  |  |
| F4230 |  | Engineering/Design standards for PFD | milestone | 0d | 2008-01-30 A | 2008-01-30 A | F2760 | 100% | F4230 | F4230 | L2 | 0E | 200 | F | 3A | PMT | 1 | E | 0B | 0000 | LUZ2 |  | LND | 001 |  |  |  |
| F4700 |  | Stepwise Handover PDP completed | milestone | 0d | 2008-01-30 A | 2008-01-30 A | F4670 | 100% | F4700 | F4700 | G | 0E | 200 | F | 3A | INE | 1 | E | 0B | 0000 | LUZ2 |  | LND | 001 | 002 |  |  |
| F3340 |  | Kick-off meeting | milestone | 0d | 2008-02-01 A | 2008-02-01 A | F4670 | 100% | F3340 | F3340 | G | 0E | 200 | F | 3A | LND | 1 | E | 0B | 0000 | LUZ2 | PI | LND | 001 | 002 |  |  |
| F3480 |  | Applicable Regulations/Standards-Gouv./PMT | milestone | 0d | 2008-02-01 A | 2008-02-01 A | F2760 | 100% | F3480 | F3480 | L2 | 0E | 200 | F | 3A | PMT | 1 | E | 0B | 0000 | LUZ2 | PI | LND | 001 |  |  |  |
| F4270 |  | Clarification Geotechnical Investig. PP Plant | milestone | 0d | 2008-02-01 A | 2008-02-01 A | F2760 | 100% | F4270 | F4270 | L2 | 0E | 200 | F | 3A | PMT | 1 | E | 0B | 0000 | LUZ2 |  | LND | 001 |  |  |  |
| F8700 |  | Utility list with Design/Battery Limit Data | milestone | 0d | 2008-02-27 A | 2008-02-27 A | F2760 | 100% | F8700 | F8700 | L3 | 0E | 200 | F | 3A | PMT | 1 | E | 0B | 0000 | LUZ2 | E | PMT | 001 | 001 |  |  |
| F3640 |  | Hazard Review/Report (part of PDP)-Licensor | milestone | 0d | 2008-02-29 A | 2008-02-29 A | F2260 FF | 100% | F3640 | F3640 | L3 | 0E | 200 | F | 3A | INE | 1 | E | 0B | 0000 | LUZ2 | PI | LND | 001 | 001 |  |  |
| F2270 |  | Interlocks, Sequences/Instrument Data Sheets | milestone | 0d | 2008-03-01 A | 2008-03-01 A | F2100 | 100% | F2270 | F2270 | I | 0E | 200 | F | 3A | INE | 1 | E | 0B | 0000 | LUZ2 | 1 | LND |  | 001 |  |  |
| F4380 |  | Standardization Piping eng./design, pipeclasses | milestone | 0d | 2008-03-04 A | 2008-03-04 A | F2760 | 100% | F4380 | F4380 | L2 | 0E | 200 | F | 3A | PMT | 1 | E | 0B | 0000 | LUZ2 |  | LND | 001 | 001 |  |  |
| F4170 |  | Engineering/Design standards for P&ID | milestone | 0d | 2008-03-14 A | 2008-03-14 A | F2760 | 100% | F4170 | F4170 | L2 | 0E | 200 | F | 3A | PMT | 1 | E | 0B | 0000 | LUZ2 |  | LND | 001 | 001 |  |  |
| F8720 |  | Construction Philosophy Decision -Sibur/PMT | milestone | 0d | 2008-04-01 A | 2008-04-01 A | F4670 | 100% | F8720 | F8720 | G | 0E | 200 | F | 3A | PMT | 1 | E | 0B | 0000 | LUZ2 | E | PMT | 001 | 002 |  |  |
| F2250 |  | Electronic Release of remain. engineering specs | milestone | 0d | 2008-04-03 A | 2008-04-03 A | F2100 | 100% | F2250 | F2250 | I | 0E | 200 | F | 3A | INE | 1 | E | 0B | 0000 | LUZ2 | 1 | LND |  | 001 |  |  |
| F2610 |  | Actual Valve & Piping Specification-PMT | milestone | 0d | 2008-04-03 A | 2008-04-03 A | F2250 FF | 100% | F2610 | F2610 | L1 | 0E | 200 | F | 3A | PMT | 1 | E | 0B | 0000 | LUZ2 | 1 | LND | 001 | 001 |  |  |
| F3470 |  | Plotplan freeze PP Plant 1st issue | milestone | 0d | 2008-05-09 A | 2008-05-09 A | F1780 FF | 100% | F3470 | F3470 | G | 0E | 200 | F | 3A | LND | 1 | E | 0B | 0000 | LUZ2 | PI | LND | 001 | 002 |  |  |
| F3490 |  | Results about GOST-R-CERTIFICAT-Gouv./PMT | milestone | 0d | 2008-05-31 A | 2008-05-31 A | F2760 | 100% | F3490 | F3490 | L2 | 0E | 200 | F | 3A | PMT | 1 | E | 0B | 0000 | LUZ2 | PI | LND | 001 | 001 |  |  |
| F3590 |  | Winterization package-Licensor | milestone | 0d | 2008-06-07 A | 2008-06-07 A | F2760 | 100% | F3590 | F3590 | L3 | 0E | 200 | F | 3A | INE | 1 | E | 0B | 0000 | LUZ2 | PI | LND | 001 | 001 |  |  |
| F3540 |  | Instrumentation & Control Design Basis-PMT | milestone | 0d | 2008-06-14 A | 2008-06-14 A | F2100 | 100% | F3540 | F3540 | L3 | 0E | 200 | F | 3A | PMT | 1 | E | 0B | 0000 | LUZ2 | PI | LND | 001 | 001 |  |  |
| F3550 |  | SIBUR Standards+Spec.'s Instrumentation-PMT | milestone | 0d | 2008-06-14 A | 2008-06-14 A | F2100 | 100% | F3550 | F3550 | L3 | 0E | 200 | F | 3A | PMT | 1 | E | 0B | 0000 | LUZ2 | PI | LND | 001 | 001 |  |  |
| F2310 |  | Cost estimate PP Plant | milestone | 0d | 2008-06-28 A | 2008-06-28 A | F2050 FS-2d, F2070, F8620, F8860, F1490, F1730, F1770, F1190, F2170, F2380, F2040 FS-2d, F1170, F3730, F1710, F1760, F1860, F1450, F2060, F1090, F1390 | 100% | F2310 | F2310 | G | 0E | 200 | F | 3A | LND | 1 | E | 0B | 0000 | LUZ2 | 1 | LND | 001 | 002 |  |  |
| F2950 |  | Gate Review Period |  | 65d | 2008-07-02 A | 2008-09-30 A | F2310 | 100% | F2950 | F2950 | G | 0E | 200 | 2 | 3A | OWN | 1 | E | 0B | 0000 | LUZ2 | P | LND | 010 | 002 |  |  |
| F3360 |  | FEED Contract | milestone | 0d | 2008-07-25 A | 2008-07-25 A | F3350 FF | 100% | F3360 | F3360 | G | 0E | 200 | F | 3A | PMT | 1 | E | 0B | 0000 | LUZ2 | PI | LND | 001 | 002 |  |  |
| A1010025 |  | P&ID's - Status E2- issue for design | milestone | 0d | 2008-08-12 A | 2008-08-12 A | AD1220 | 100% | A1010025 | A1010025 | G | 0E | 200 | AD |  | LND |  | E | 0B | 0000 | LUZ2 | 1 |  | 200 |  |  |  |
| A1010027 |  | Start underground piping design | milestone | 0d | 2008-09-01 A | 2008-09-01 A | F4470 | 100% | A1010027 | A1010027 | G | 0E | 200 | F |  | LND |  | E | 0B | 0000 | LUZ2 | PL |  | 200 |  |  |  |
| F3600 |  | Masterplotplan PDH/PP Plant confirmed PMT | milestone | 0d | 2008-09-11 A | 2008-09-11 A | F4670 | 100% | F3600 | F3600 | G | 0E | 200 | F | 3A | PMT | 1 | E | 0B | 0000 | LUZ2 | PI | LND | 001 | 002 |  |  |
| F3920 |  | PUE/IEC utilization cable trays -decision need- | milestone | 0d | 2008-09-18 A | 2008-09-18 A | F2100 | 100% | F3920 | F3920 | L3 | 0E | 200 | F | 3A | PMT | 1 | E | 0B | 0000 | LUZ2 | PI | LND | 001 | 001 |  |  |
| F3670 |  | Insulation standards/Specification-PMT | milestone | 0d | 2008-10-01 A | 2008-10-01 A | F2760 | 100% | F3670 | F3670 | L1 | 0E | 200 | F | 3A | PMT | 1 | E | 0B | 0000 | LUZ2 | PI | LND | 001 | 001 |  |  |
| F3950 |  | Standardization Electrical eng./design standards | milestone | 0d | 2008-10-01 A | 2008-10-01 A | F2760 | 100% | F3950 | F3950 | L2 | 0E | 200 | F | 3A | PMT | 1 | E | 0B | 0000 | LUZ2 | PI | LND | 001 | 001 |  |  |
| F4190 |  | Standardization f. Instrumentation eng./design | milestone | 0d | 2008-10-01 A | 2008-10-01 A | F2760 | 100% | F4190 | F4190 | L2 | 0E | 200 | F | 3A | PMT | 1 | E | 0B | 0000 | LUZ2 |  | LND | 001 | 001 |  |  |
| F4210 |  | Standard. for Instrument. dev./automated valves | milestone | 0d | 2008-10-01 A | 2008-10-01 A | F2760 | 100% | F4210 | F4210 | L2 | 0E | 200 | F | 3A | PMT | 1 | E | 0B | 0000 | LUZ2 |  | LND | 001 | 001 |  |  |
| F4250 |  | Standardization Civil eng./design standards | milestone | 0d | 2008-10-01 A | 2008-10-01 A | F2760 | 100% | F4250 | F4250 | L2 | 0E | 200 | F | 3A | PMT | 1 | E | 0B | 0000 | LUZ2 |  | LND | 001 | 001 |  |  |
| F4300 |  | Standardization BoQ for Civil,E+I,Mechanical | milestone | 0d | 2008-10-01 A | 2008-10-01 A | F2760 | 100% | F4300 | F4300 | L2 | 0E | 200 | F | 3A | PMT | 1 | E | 0B | 0000 | LUZ2 |  | LND | 001 | 001 |  |  |
| F4420 |  | Standardization Safety eng./design standards | milestone | 0d | 2008-10-01 A | 2008-10-01 A | F2760 | 100% | F4420 | F4420 | L2 | 0E | 200 | F | 3A | PMT | 1 | E | 0B | 0000 | LUZ2 |  | LND | 001 | 001 |  |  |
| F2670 |  | FEED finish | milestone | 0d | 2008-10-31 A | 2008-10-31 A | F1030, F1150, F2660, F1510 FF, F3620, F2500, F8730, F1790, F1310, F1210, F1930, F2010, F2530, F2630, F2580, F1350, F1330, F8760, F1180, F1600 FF, F2650, F2320, F2720, F1290, F1590, F2520, F1850, F1270, F1220, F3650, F1980, F8800, F2620, F1920, F8980, F2510 FF, F1900, F1500 FF, F1820, F2590, F2750 FS-5d, F1230, F1200, F1470, F8840, F8770, F1740, F2570, F2400, F1370, F1410, F8710, F1260, F8970, F1890, F1010, F1160, F2000, F2560, F1380, F1040 | 100% | F2670 | F2670 | G | 0E | 200 | F | 3A | LND | 1 | E | 0B | 0000 | LUZ2 | 1 | LND | 001 | 002 |  |  |
| AD5500 |  | Advanced Detail Engineering finish | milestone | 0d | 2008-11-29 A | 2008-11-29 A | AD1740 FF | 100% | AD5500 | AD5500 | G | 0E | 200 | F | 3A | LND | 1 | E | 0B | 0000 | LUZ2 | INS | LND | 001 | 002 |  |  |
| A1010024 |  | P&ID's - Status F |  | 55d | 2008-12-01 A | 2009-02-20 A | A1CF0235 | 100% | A1010024 | A1010024 | G | 0E | 200 | E |  | LND |  | E | 0B | 0000 | LUZ2 | 1 |  | 200 |  |  |  |
| A1010037 |  | PID Download Status E2 f. Inquiry Pipemat. | milestone | 0d | 2008-12-01 A | 2008-12-01 A | AD1220 | 100% | A1010037 | A1010037 | G | 0E | 200 | AD |  | LND |  | E | 0B | 0000 | LUZ2 | ML | LND | 200 |  |  |  |
| F3970 |  | HIPS for flare Y/N -decision need- | milestone | 0d | 2008-12-31 A | 2008-12-31 A | F2100 | 100% | F3970 | F3970 | L3 | 0E | 200 | F | 3A | PMT | 1 | E | 0B | 0000 | LUZ2 | PI | LND | 001 | 001 |  |  |
| F4130 |  | Overall Plotplan PP Plant Layout known | milestone | 0d | 2008-12-31 A | 2008-12-31 A | F4670 | 100% | F4130 | F4130 | G | 0E | 200 | F | 3A | PMT |  | E | 0B | 0000 | LUZ2 |  | LND | 001 | 002 |  |  |
| A1010033 |  | 2. MTO Piping Material | milestone | 0d | 2009-01-16 A | 2009-01-16 A | A1KL1133 SS | 100% | A1010033 | A1010033 | G | 0E | 200 | E |  | LND |  | E | 0B | 0000 | LUZ2 | PL |  | 200 |  |  |  |
| ES100100 |  | Instruction by Client for add. Scope (Flare) | milestone | 0d | 2009-03-03 A | 2009-03-03 A | F1000 | 100% | ES100100 | ES100100 | 871 | 0E |  | E |  | PMT | FL | E | 0B | 0000 | LUZ2 | 1 | LND |  |  | A18 | 2DD0330 |
| EL10010 |  | Design Review finalized DRV 60% - downstream | milestone | 0d | 2009-10-27 A | 2009-10-27 A | F4035 FF | 100% | EL10010 | EL10010 | G | 0E | 200 | E |  | LND |  | E | 0B | 0000 | LUZ2 | I | LND | 200 |  |  |  |
| EL10020 |  | Design Review finalized DRV 60% - 11/12/13/51,55-56 | milestone | 0d | 2009-11-17 A | 2009-11-17 A | F4030 FF, EL10010 | 100% | EL10020 | EL10020 | G | 0E | 200 | E |  | LND |  | E | 0B | 0000 | LUZ2 | I | LND | 200 |  |  |  |

Notes:
- F2270: P3 Activity Log Info: incomplete
- F2610: P3 Activity Log Info: commited delivery date / 14DEC07
- F3600: P3 Activity Log Info: commited delivery date / 31DEC07 Blast calc warehouse outstanding
- F3670: P3 Activity Log Info: commited delivery date / 14DEC07
- F4130: P3 Activity Log Info: commited delivery date / 31DEC07

| ID | WBS | Activity | Type | Duration | Start | Finish | Predecessors | Complete | Constraint | Calendar | UDF_SAVE ACTID | UDF_SAVE ACT ID | Department | Constr. Area | PMT-Area | PMT-Schedule Org | PMT-Discipline | PMT-Phase | PMT-Stage | PMT-Respons. | Zeigen/n. Zeigen | WBS Phase | WBS Discipline | WBS Type of Work | WBS Objects | UPT | IMS | Filter | Pro Unit/DocCode | Type of Work | Inquiry/Order No |
| --- | --- | --- | --- | --- | --- | --- | --- | --- | --- | --- | --- | --- | --- | --- | --- | --- | --- | --- | --- | --- | --- | --- | --- | --- | --- | --- | --- | --- | --- | --- | --- |
| DE1000 |  | EPC Contract award | milestone | 0d | 2009-11-30 A | 2009-11-30 A | F4670 | 100% |  |  | DE1000 | DE1000 | G | 0E | 200 | 001 | 002 | F | 3A | PMT | 1 | E | 0B | 0000 | LUZ2 | LND |  |  |  |  |  |
| A1010034 |  | 3. MTO Piping Material | milestone | 0d | 2010-02-03 A | 2010-02-03 A | A1KL1135 SS | 100% |  |  | A1010034 | A1010034 | G | 0E | 200 | 200 |  | E |  | LND |  | E | 0B | 0000 | LUZ2 | LND | PL |  |  |  |  |
| EL20010 |  | Design Review finalized DRV 90% - downstream | milestone | 0d | 2010-05-07 A | 2010-05-07 A | F9250 FF, EL10010 | 100% |  |  | EL20010 | EL20010 | G | 0E | 200 | 200 |  | E |  | LND |  | E | 0B | 0000 | LUZ2 | LND | I |  |  |  |  |
| EL20020 |  | Design Review finalized DRV 90% - 11/12/13/16/51-56 | milestone | 0d | 2010-07-09 A | 2010-07-09 A | EL10020, F4460 FF | 100% |  |  | EL20020 | EL20020 | G | 0E | 200 | 200 |  | E |  | LND |  | E | 0B | 0000 | LUZ2 | LND | I |  |  |  |  |
| EL20050 |  | Start Releasing of Isometrics AG-Piping (CA51) | milestone | 0d | 2010-08-02 A | 2010-08-02 A | F4460 FS+15d | 100% |  |  | EL20050 | EL20050 | G | 0E | 200 | 200 |  | E |  | LND |  | E | 0B | 0000 | LUZ2 | LND | 5 |  |  |  |  |
| EC20070 |  | LD Milestone 7 - Main Equipment Foundation Drwgs 90% released | milestone | 0d | 2010-08-13 A | 2010-08-13 A | EC48122203 FF, EC285101 FF, EC28130410 FF, EC281321 FF, EC281330 FF, EC28111010 FF, EC281221 FF, EC28170810 FF, EC285402 FF, EC285502 FF, EC285503 FF, EC48161005 FF, EC48171003 FF, EC285401 FF, EC28130105 FF, EC48132203 FF, EC281332 FF, EC48313003 FF, EC28120410 FF, EC281205 FF, EC48122103 FF, EC48161003 FF, EC28170710 FF, EC48312003 FF, EC48314003 FF, EC285104 FF, EC285501 FF, EC285601 FF, EC48111003 FF, EC28120105 FF, EC281230 FF, EC281232 FF, EC285102 FF, EC281111 FF, EC285103 FF, EC48132103 FF, EC28311005 FF | 100% |  |  | EC20070 | EC20070 | G | 0E | 200 | 200 |  | E |  | LND |  | E | 0B | 0000 | LUZ2 | LND | 2 | 1 |  |  |  |
| EC20060 |  | LD Milestone 3 - Electrical Substation - AFC Layout | milestone | 0d | 2010-08-24 A | 2010-08-24 A | EC48161004 FF, EC48161012 FF, EC521610 FF, EC501610 FF, EC45161005 FF, EC48161008 FF, EC48161015 FF, EC48161006 FF, EC48161010 FF, EC48161003 FF, EC48161005 FF, EC48161007 FF, EC151610 FF | 100% |  | TB26 - 3 - Construct-normal * | EC20060 | EC20060 | G | 0E | 200 | 200 |  | E |  | LND |  | E | 0B | 0000 | LUZ2 | LND | 5 | 1 |  |  |  |
| EL20060 |  | LD Milestone 1 - 90% Model review finalized | milestone | 0d | 2010-09-17 A | 2010-09-17 A | F4460, F9250, F4462 | 100% |  |  | EL20060 | EL20060 | G | 0E | 200 | 200 |  | E |  | LND |  | E | 0B | 0000 | LUZ2 | LND | 5 | 1 |  |  |  |
| EC20080 |  | LD Milestone 10a - Building Layout Drwgs (number) 95% excluding CA17 released | milestone | 0d | 2010-09-30 A | 2010-09-30 A | EC45312005, EC45132105, EC45314005, EC45111005, EC45122205, EC45311005, EC45313005, EC45122105, EC45161005, EC45132205 | 100% |  |  | EC20080 | EC20080 | G | 0E | 200 | 200 |  | E |  | LND |  | E | 0B | 0000 | LUZ2 | LND | 2 | 1 |  |  |  |
| EC20090 |  | LD Milestone 10b - Building Layout Drwgs (number) 95% for CA17 released | milestone | 0d | 2010-10-29 A | 2010-10-29 A | EC45170005 | 100% |  |  | EC20090 | EC20090 | G | 0E | 200 | 200 |  | E |  | LND |  | E | 0B | 0000 | LUZ2 | LND | 2 | 1 |  |  |  |
| EJ20060 |  | LD Milestone 4 - AFC Loop Diagramms 90% | milestone | 0d | 2010-12-09 A | 2010-12-09 A | EJ801232 FF, EJ801736 FF, EJ801760 FF, EJ801322 FF, EJ801222 FF, EJ803110 FF, EJ801330 FF, EJ801111, EJ801230 FF, EJ801233 FF, EJ801301 FF, EJ801221 FF, EJ801710 FF, EJ801720 FF, EJ801740 FF, EJ801730 FF, EJ803120 FF, EJ801321 FF, EJ801332 FF, EJ801110, EJ801201, EJ801718 FF, EJ803140 FF | 100% |  | TB26 - 3 - Construct-normal * | EJ20060 | EJ20060 | G | 0E | 200 | 200 |  | E |  | LND |  | E | 0B | 0000 | LUZ2 | LND | 5 | 1 |  |  |  |
| EF20070 |  | LD Milestone 6 - P&ID's approved f.construction (AFC-Status H) | milestone | 0d | 2010-12-27 A | 2010-12-27 A | IMS-E-000040 FF, IMS-E-000043 FF, IMS-E-000041 FF, IMS-E-000042 FF, IMS-E-000046 FF, IMS-E-000030 FF, IMS-E-000035 FF | 100% |  |  | EF20070 | EF20070 | G | 0E | 200 | 200 |  | E |  | LND |  | E | 0B | 0000 | LUZ2 | LND | 2 | 1 |  |  |  |
| EN20050 |  | LD Milestone 2 - Main Structural Steel AFC Drwgs 90% released | milestone | 0d | 2010-12-31 A | 2010-12-31 A | EN27130405 FF, EN27170805 FF, EN27171115 FF, EN27550305 FF, EN27120405 FF, EN27171140 FF, EN27312005 FF, EN27550205 FF, EN27130505 FF, EN27171125 FF, EN27310005 FF, EN27510105 FF, EN27510405 FF, EN27311015 FF, EN27540105 FF, EN27111105 FF, EN27120505 FF, EN27311505 FF, EN27510205 FF, EN27111005 FF, EN27120105 FF, EN27311005 FF, EN27311025 FF, EN27313005 FF, EN27540205 FF, EN27560105 FF, EN27130105 FF, EN27510305 FF, EN27170705 FF, EN27171105 FF, EN27314005 FF, EN27520105 FF, EN27550105 FF | 100% |  | TB26 - 3 - Construct-normal * | EN20050 | EN20050 | G | 0E | 200 | 200 |  | E |  | LND |  | E | 0B | 0000 | LUZ2 | LND | 5 | 1 |  |  |  |
| EL20070 |  | LD Milestone 5 - AG Isometrics and BOM 90% released | milestone | 0d | 2011-01-06 A | 2011-01-06 A | ER491304 SF, ER491321 SF, ER491332 SF, ER491730 SF-11d, ER491740 SF-11d, ER491110 FF, ER491204 SF, ER491708 SF-11d, ER491710 SF-11d, ER491760 SF-11d, ER493140 SF, ER495402 SF, ER491233 SF, ER493110 SF, ER495601 SF, ER491301 SF, ER491111 FF, ER491221 SF, ER491232 SF, ER491718 SF-11d, ER493120 SF, ER495104 SF, ER495502 SF, ER491330 SF, ER491230 SF, ER491707 SF-11d, ER495501 SF, ER495201 SF, ER495503 SF, ER491322 SF, ER495101 SF, ER495103 SF, ER495401 SF, ER491201 SF, ER491222 SF, ER491720 SF-11d, ER491736 SF-11d, ER493130 SF, ER495102 SF | 100% | finish on 2011-01-06 |  | EL20070 | EL20070 | G | 0E | 200 | 200 |  | E |  | LND |  | E | 0B | 0000 | LUZ2 | LND | 5 | 1 |  |  |  |
| EL20080 |  | LD Milestone 9 - Final MTO - 90% Piping Material available for pre-fabrication | milestone | 0d | 2011-03-21 A | 2011-03-21 A | P3R02S1 FF, P3R06BS1 FF, P3R06CS1 FF, P3R02AS1 FF, P3R06AS1 FF, P3R06CS FF-25d, P3R02AS FF-20d, P3R02S FF, P3R06S1 FF, P3R06DS1 FF | 100% | finish on 2011-03-17 |  | EL20080 | EL20080 | G | 0E | 200 | 200 |  | E |  | LND |  | E | 0B | 0000 | LUZ2 | LND | 2 | 1 |  |  |  |
| P030010 |  | PDN0048 - Engineering/Procurement Central Chiller Unit Part approved | milestone | 0d | 2011-04-11 A | 2011-04-11 A | F3080 SF | 100% | finish on 2011-04-11 |  | P020060 | P030010 | G | 0E | 200 | 200 |  | E |  | LND |  | E | 0B | 0000 | LUZ2 | LND | 2 | 1 |  |  |  |
| P020060 |  | LD Milestone 8 - LLE Main Delivery complete | milestone | 0d | 2011-04-15 A | 2011-04-15 A | P3A05S1 FF, P3M06S1 FF, P3M11S1 FF, P3A03S1, P3U10S2A FF, P3A16S FF, P3A05S2, P3M11S2, P3M02S2, P3U10S1 FF, P3A13S3B, P3A04AS2 FF, P3A13S2A, P3M01SB FF, P3A04AS1 FF, P3M02S1 FF, P3M15S2, P3A08S FF, P3A07S1 FF, P3A13S1A, P3M01SA FF, P3ALL1S1 FF, P3M05S1 FF, P3A07S2, P3A13S2B, P3M15S1, P3U10S3 FF, P3A13S3A, P3M03S1 FF, P3A13S1B, P3A02S6 FF, P3M01SC FF, P3M06S2, P3M05S2, P3A13S4, P3U02S1 FF, P3ALL4S1 FF | 100% | finish on 2011-04-15 |  | P020060 | P020060 | G | 0E | 200 | 200 |  | E |  | LND |  | E | 0B | 0000 | LUZ2 | LND | 2 | 1 |  |  |  |
|  | J | **J Instrumentation** |  |  | 2008-08-01 | 2008-08-01 |  |  |  |  |  |  |  |  |  |  |  |  |  |  |  |  |  |  |  |  |  |  |  |  |  |
| AD1890 |  | PMT-FEED-Documents for Instrument. available | milestone | 0d | 2008-08-01 A | 2008-08-01 A | F2760 | 100% |  |  | AD1890 | AD1890 | 86A | 0E | 200 | 200 | 070 | AD | 3A | PMT | 1 | E | J | 0000 | LUZ2 | LND | INS |  | 999 |  |  |
|  | R | **R Piping** |  |  | 2008-12-01 | 2009-09-30 |  |  |  |  |  |  |  |  |  |  |  |  |  |  |  |  |  |  |  |  |  |  |  |  |  |
| A1010032 |  | 1st MTO Piping Material | milestone | 0d | 2008-12-01 A | 2008-12-01 A | AD2050, AD2060 | 100% |  |  | A1010032 | A1010032 | 873 | 0E | 200 | 200 |  | AD |  | LND |  | E | R | ER00 | LUZ2 |  | PL |  |  |  |  |
| E3R0215 |  | R02 UG GFK Pipes - Prel.Bid for PMT review | milestone | 0d | 2009-03-12 A | 2009-03-12 A | E3R0220 SS-12d | 100% |  |  | E3R0215 | E3R0215 | 873 | 00 | 200 | 200 | 055 | E |  | LND | 0 | E | R | ER24 | LUZ2 | LND | PL |  |  | R02 | 2RE1350 |
| E3R02A15 |  | R02A UG Cast Iron Pipes - Prel.Bid for PMT review | milestone | 0d | 2009-03-12 A | 2009-03-12 A | E3R02A20 SS-20d | 100% |  |  | E3R02A15 | E3R02A15 | 873 | 00 | 200 | 200 | 055 | E |  | LND | 0 | E | R | ER24 | LUZ2 | LND | PL |  |  | R02A | 2RE2240 |
| E3R02B15 |  | R02B HDPE Pipes - Prel.Bid for PMT review | milestone | 0d | 2009-03-12 A | 2009-03-12 A | E3R02B20 SS-20d | 100% |  |  | E3R02B15 | E3R02B15 | 873 | 00 | 200 | 200 | 055 | E |  | LND | 0 | E | R | ER24 | LUZ2 | LND | PL |  |  | R02B | 2RE2290 |
| E3R0615 |  | R06 AG Fittings CS - Prel.Bid for PMT review | milestone | 0d | 2009-09-14 A | 2009-09-14 A | E3R0620 SS-3d | 100% |  |  | E3R0615 | E3R0615 | 873 | 00 | 200 | 200 | 055 | E |  | LND | 0 | E | R | ER24 | LUZ2 | LND | PL |  |  | R06 | 2RE1820 |
| E3R06A15 |  | R06A AG Fittings SS - Prel.Bid for PMT review | milestone | 0d | 2009-09-14 A | 2009-09-14 A | E3R06A20 SS-3d | 100% |  |  | E3R06A15 | E3R06A15 | 873 | 00 | 200 | 200 | 055 | E |  | LND | 0 | E | R | ER24 | LUZ2 | LND | PL |  |  | R06A | 2RE1830 |
| E3R06B15 |  | R06B AG Pipes CS - Prel.Bid for PMT review | milestone | 0d | 2009-09-14 A | 2009-09-14 A | E3R06B20 SS-3d | 100% |  |  | E3R06B15 | E3R06B15 | 873 | 00 | 200 | 200 | 055 | E |  | LND | 0 | E | R | ER24 | LUZ2 | LND | PL |  |  | R06B | 2RE1800 |
| E3R06C15 |  | R06C AG Pipes SS - Prel.Bid for PMT review | milestone | 0d | 2009-09-14 A | 2009-09-14 A | E3R06C20 SS-3d | 100% |  |  | E3R06C15 | E3R06C15 | 873 | 00 | 200 | 200 | 055 | E |  | LND | 0 | E | R | ER24 | LUZ2 | LND | PL |  |  | R06C | 2RE1810 |
| E3R06D15 |  | R06D AG Flanges CS/SS - Prel.Bid for PMT review | milestone | 0d | 2009-09-14 A | 2009-09-14 A | E3R06D20 SS-3d | 100% |  |  | E3R06D15 | E3R06D15 | 873 | 00 | 200 | 200 | 055 | E |  | LND | 0 | E | R | ER24 | LUZ2 | LND | PL |  |  | R06D | 2RE1840 |
| E3R0415 |  | R04 AG Gate Valves - Prel.Bid for PMT review | milestone | 0d | 2009-09-30 A | 2009-09-30 A | E3R0420 SS-3d | 100% |  |  | E3R0415 | E3R0415 | 873 | 00 | 200 | 200 | 055 | E |  | LND | 0 | E | R | ER24 | LUZ2 | LND | PL |  |  | R04 | 2AC2600 |

| ID | WBS | Activity | Type | Duration | Start | Finish | Predecessors | Complete | Total float | Free float | Resources | Cost | Actual cost | UDF_SAVE ACTID | UDF_SAVE ACT ID | Department | Constr. Area | PMT-Area | PMT-Schedule Org | PMT-Discipline | PMT-Phase | PMT-Stage | PMT-Respons. | Zeigen/n. Zeigen | WBS Phase | WBS Discipline | WBS Type of Work | WBS Objects | IMS | UPT | Type of Work | Pro Unit/DocCode | Inquiry/Order No | PMT-Doc. Type | TB26 Ressource Budget |
| --- | --- | --- | --- | --- | --- | --- | --- | --- | --- | --- | --- | --- | --- | --- | --- | --- | --- | --- | --- | --- | --- | --- | --- | --- | --- | --- | --- | --- | --- | --- | --- | --- | --- | --- | --- |
|  | S | **S Safety & Environment** |  |  | 2008-12-31 | 2008-12-31 |  |  |  |  |  |  |  |  |  |  |  |  |  |  |  |  |  |  |  |  |  |  |  |  |  |  |  |  |  |
| AD1370 |  | HIPS for flare Y/N -decision need- | milestone | 0d | 2008-12-31 A | 2008-12-31 A | F3970 FF | 100% |  |  |  |  |  | AD1370 | AD1370 | 871 | 0E | 200 | 001 | 001 | F | 3A | PMT | 1 | E | S | 0000 | LUZ2 | INS | LND |  |  |  |  |  |
|  | 00 | **00 Construction Areas - General** |  |  | 2008-02-01 | 2011-12-13 |  |  |  |  |  |  |  |  |  |  |  |  |  |  |  |  |  |  |  |  |  |  |  |  |  |  |  |  |  |
|  | LUZ2 | **LUZ2 General ( )** |  |  | 2008-02-25 | 2011-12-13 |  |  |  |  |  |  |  |  |  |  |  |  |  |  |  |  |  |  |  |  |  |  |  |  |  |  |  |  |  |
|  | B | **B Mechanical - Stationary Equipment** |  |  | 2008-02-27 | 2011-12-13 |  |  |  |  |  |  |  |  |  |  |  |  |  |  |  |  |  |  |  |  |  |  |  |  |  |  |  |  |  |
| F8460 |  | A04 R Overhead Sep.- Prel.Bid tab for PMT review |  | 6d | 2008-02-27 A | 2008-03-05 A | F8410, F8530 | 100% |  |  |  |  |  | F8460 | F8460 | 869 | 00 | 200 | 200 | 400 | P |  | LND | C2 | E | B | EB24 | LUZ2 | E | PMT | A04 | DC | 2DC8500 |  |  |
| F7850 |  | ALL2 Purge Columns- Prel.Bid tab for PMT review |  | 6d | 2008-03-04 A | 2008-03-11 A | F7800 | 100% |  |  |  |  |  | F7850 | F7850 | 869 | 00 | 200 | 200 | 400 | P | 3A | LND | C2 | E | B | EB44 | LUZ2 | 1 | LND | ALL2 | DC | 2DC8500 |  |  |
| F7010 |  | A05 Offgas Cyclone&R - Prel.Bid tab for PMT rev |  | 4d | 2008-03-07 A | 2008-03-12 A | F6960 FS+9d | 100% |  |  |  |  |  | F7010 | F7010 | 869 | 00 | 200 | 200 | 400 | P | 3A | LND | C2 | E | B | EB94 | LUZ2 | 1 | LND | A05 | DC | 2DC8590 |  |  |
| F5610 |  | A08 Vent/Bag Filter- Prel.Bid tab for PMT review |  | 5d | 2008-03-10 A | 2008-03-14 A | F5560 | 100% |  |  |  |  |  | F5610 | F5610 | 869 | 00 | 200 | 200 | 400 | P | 3A | LND | C2 | E | B | EB84 | LUZ2 | 1 | LND | A08 | DC | 2DC8560 |  |  |
| F5110 |  | A07 R Fines Eductor- Prel.Bid tab for PMT review |  | 3d | 2008-03-25 A | 2008-03-27 A | F5060 | 100% |  |  |  |  |  | F5110 | F5110 | 869 | 00 | 200 | 200 | 400 | P | 3A | LND | C2 | E | B | EB94 | LUZ2 | 1 | LND | A07 | DC | 2DC8640 |  |  |
| F5810 |  | A16 Offgas C Filter- Prel.Bid tab for PMT review |  | 3d | 2008-03-28 A | 2008-04-01 A | F5760 | 100% |  |  |  |  |  | F5810 | F5810 | 869 | 00 | 200 | 200 | 400 | P | 3A | LND | C2 | E | B | EB84 | LUZ2 | 1 | LND | A16 | DC | 2DC8560 |  |  |
| F10050 |  | ALL4 Silo's - Prel.Bid tab for PMT review |  | 5d | 2008-06-23 A | 2008-06-27 A | F10040 | 100% |  |  |  |  |  | F10050 | F10050 | 869 | 00 | 200 | 200 | 400 | P |  | LND | C2 | E | B | EB64 | LUZ2 | 1 | LND | ALL4 | DC | 2DC9000 |  |  |
| E3A02A10 |  | A02A Large Drums - Inquiry Spec. |  | 9d | 2008-07-01 A | 2008-07-11 A | F1670 SS+65d | 100% |  |  |  |  |  | E3A02A10 | E3A02A10 | 869 | 00 | 200 | 200 | 055 | E |  | LND | 0 | E | B | EB13 | LUZ2 | 3 | LND | A02A |  | 2DC9450 | DEV |  |
| F5310 |  | A04A R Overhead Cond. - Prel.Bid tab for PMT rev |  | 7d | 2008-07-29 A | 2008-08-06 A | F5260 FS+1d | 100% |  |  |  |  |  | F5310 | F5310 | 869 | 00 | 200 | 200 | 400 | P | 3A | LND | C2 | E | B | EB24 | LUZ2 | 1 | LND | A04A | DC | 2DC9110 |  |  |
| E3A02A20 |  | A02A Large Drums - Techn. Eval./PO Spec |  | 410d | 2008-11-26 A | 2010-07-19 A | P3A02AB FS+92d | 100% |  |  | TAA [1200 h] |  |  | E3A02A20 | E3A02A20 | 869 | 00 | 200 | 200 | 055 | E |  | LND | 0 | E | B | EB14 | LUZ2 | 2 | LND | A02A |  | 2DC9450 |  | 1200,00 |
| E3A02A30 |  | A02A Large Drums - Techn. Eval./Bid Tab F | milestone | 0d | 2010-05-25 A | 2010-05-25 A | E3A02A15 SF, E3A02A20 FF-8d | 100% |  |  |  |  |  | E3A02A30 | E3A02A30 | 869 | 00 | 200 | 200 | 055 | E |  | LND | 0 | E | B | EB14 | LUZ2 | 2 | LND | A02A |  | 2DC9450 |  |  |
| E3A02A40 |  | A02A Large Drums - 1st Review dwgs |  | 19d | 2010-09-28 A | 2010-10-22 A | P3A02AL SS+70d | 100% |  |  | TAA [1200 h] |  |  | E3A02A40 | E3A02A40 | 869 | 00 | 200 | 200 | 055 | E |  | LND | 0 | E | B | EB15 | LUZ2 | 3 | LND | A02A |  | 2DC9450 |  | 1200,00 |
| E3A02A50 |  | A02A Large Drums - Vendor dwgs approved | milestone | 0d | 2010-10-22 A | 2010-10-22 A | E3A02A40 FF | 100% |  |  |  | 90,920 | 90,920 | E3A02A50 | E3A02A50 | 869 | 00 | 200 | 200 | 055 | E |  | LND | 0 | E | B | EB15 | LUZ2 | 3 | LND | A02A |  | 2DC9450 | DFA |  |
| E3A02A60 |  | A02A Large Drums - 2nd Review dwgs |  | 15d | 2010-11-08 A | 2010-11-29 A | P3A02AL SS+110d, E3A02A50 | 100% |  |  | TAA [800 h] |  |  | E3A02A60 | E3A02A60 | 869 | 00 | 200 | 200 | 055 | E |  | LND | 0 | E | B | EB15 | LUZ2 | 3 | LND | A02A |  | 2DC9450 |  | 800,00 |
| E3A02D10 |  | A02D Vessels Chiller Unit - Inquiry Spec. |  | 10d | 2011-04-26 A | 2011-05-09 A | EF00210 SS, P030010 FS+10d | 100% |  |  |  |  |  | E3A02A10 | E3A02D10 | 869 | 00 | 200 | 200 | 055 | E |  | LND |  | E | B | EB13 | LUZ2 | 3 | LND | A02D |  | A02D | DEV |  |
| E3M1810 |  | M18 Pumps Chiller Unit - Inquiry Spec. |  | 10d | 2011-04-26 A | 2011-05-09 A | P030010 FS+10d, EF00210 SS | 100% |  |  |  |  |  | E3A02A10 | E3M1810 | 867 | 00 | 200 | 200 | 055 | E |  | LND |  | E | M | EM13 | LUZ2 | 3 | LND | M18 |  | 2PA6720 | DEV |  |
| E3A02D20 |  | A02D Vessels Chiller Unit - Techn. Eval./PO Spec |  | 50d | 2011-06-03 A | 2011-08-11 A | P3A02DB FS+15d | 100% |  |  |  |  |  | E3A02A20 | E3A02D20 | 869 | 00 | 200 | 200 | 055 | E |  | LND |  | E | B | EB14 | LUZ2 | 2 | LND | A02D |  | A02D |  |  |
| E3M1820 |  | M18 Pumps Chiller Unit - Techn. Eval./PO Spec |  | 35d | 2011-06-10 A | 2011-07-28 A | P3M18B FS+20d | 100% |  |  |  |  |  | E3A02A20 | E3M1820 | 867 | 00 | 200 | 200 | 055 | E |  | LND |  | E | M | EM24 | LUZ2 | 2 | LND | M18 |  | 2PA6720 |  |  |
| E3A02D30 |  | A02D Vessels Chiller Unit - Techn. Eval./Bid Tab F | milestone | 0d | 2011-06-28 A | 2011-06-28 A | E3A02D20 FF-8d | 100% |  |  |  |  |  | E3A02A30 | E3A02D30 | 869 | 00 | 200 | 200 | 055 | E |  | LND |  | E | B | EB14 | LUZ2 | 2 | LND | A02D |  | A02D |  |  |
| E3M1830 |  | M18 Pumps Chiller Unit - Techn. Eval./Bid Tab F | milestone | 0d | 2011-07-19 A | 2011-07-19 A | E3M1820 FF-8d | 100% |  |  |  |  |  | E3A02A30 | E3M1830 | 867 | 00 | 200 | 200 | 055 | E |  | LND |  | E | M | EM24 | LUZ2 | 2 | LND | M18 |  | 2PA6720 |  |  |
| E3M1840 |  | M18 Pumps Chiller Unit - 1st Review dwgs |  | 10d | 2011-09-06 | 2011-09-19 | P3M18L SS+35d |  | 396.5d | 0d |  |  |  | E3A02A40 | E3M1840 | 867 | 00 | 200 | 200 | 055 | E |  | LND |  | E | M | EM25 | LUZ2 | 3 | LND | M18 |  | 2PA6720 |  |  |
| E3A02D40 |  | A02D Vessels Chiller Unit - 1st Review dwgs |  | 10d | 2011-09-12 | 2011-09-23 | P3A02DL SS+30d |  | 392.5d | 0d |  |  |  | E3A02A40 | E3A02D40 | 869 | 00 | 200 | 200 | 055 | E |  | LND |  | E | B | EB15 | LUZ2 | 3 | LND | A02D |  | A02D |  |  |
| E3M1850 |  | M18 Pumps Chiller Unit - Vendor dwgs approved | milestone | 0d | 2011-09-19 | 2011-09-19 | E3M1840 FF |  | 396.5d | 4d |  |  |  | E3A02A50 | E3M1850 | 867 | 00 | 200 | 200 | 055 | E |  | LND |  | E | M | EM25 | LUZ2 | 3 | LND | M18 |  | 2PA6720 | DFA |  |
| E3A02D50 |  | A02D Vessels Chiller Unit - Vendor dwgs approved | milestone | 0d | 2011-09-23 | 2011-09-23 | E3A02D40 FF |  | 392.5d | 0d |  |  |  | E3A02A50 | E3A02D50 | 869 | 00 | 200 | 200 | 055 | E |  | LND |  | E | B | EB15 | LUZ2 | 3 | LND | A02D |  | A02D | DFA |  |
| E3M1860 |  | M18 Pumps Chiller Unit - 2nd Review dwgs |  | 10d | 2011-10-04 | 2011-10-17 | E3M1850, P3M18L SS+60d |  | 405.5d | 39d |  |  |  | E3A02A60 | E3M1860 | 867 | 00 | 200 | 200 | 055 | E |  | LND |  | E | M | EM25 | LUZ2 | 3 | LND | M18 |  | 2PA6720 |  |  |
| E3A02D60 |  | A02D Vessels Chiller Unit - 2nd Review dwgs |  | 10d | 2011-11-30 | 2011-12-13 | P3A02DL SS+110d, E3A02D50 |  | 362.5d | 0d |  |  |  | E3A02A60 | E3A02D60 | 869 | 00 | 200 | 200 | 055 | E |  | LND |  | E | B | EB15 | LUZ2 | 3 | LND | A02D |  | A02D |  |  |

Notes:
- E3A02A50: Expenses: 900A 90920

| ID | WBS | Activity | Type | Duration | Start | Finish | Predecessors | Complete | Remaining | Total float | Free float | Resources | Cost | Actual cost | UDF_SAVE ACTID | UDF_SAVE ACT ID | Department | Type of Work | Constr. Area | Inquiry/Order No | PMT-Area | PMT-Schedule Org | PMT-Discipline | PMT-Phase | PMT-Doc. Type | PMT-Respons. | Zeigen/n. Zeigen | WBS Phase | WBS Discipline | WBS Type of Work | WBS Objects | IMS | UPT | TB26 Ressource Budget | Pro Unit/DocCode | PMT-Stage |
| --- | --- | --- | --- | --- | --- | --- | --- | --- | --- | --- | --- | --- | --- | --- | --- | --- | --- | --- | --- | --- | --- | --- | --- | --- | --- | --- | --- | --- | --- | --- | --- | --- | --- | --- | --- | --- |
|  | E | **E Electrical** |  |  | 2008-02-25 | 2010-12-15 |  |  |  |  |  |  |  |  |  |  |  |  |  |  |  |  |  |  |  |  |  |  |  |  |  |  |  |  |  |  |
| E3E0410 |  | R. Gear Motors - Inquiry Spec. |  | 10d | 2008-02-25 A | 2008-03-07 A | P3M11B FF | 100% |  |  |  |  |  |  | E3E0410 | E3E0410 | 87D | E04 | 00 | 2KB2429 | 200 | 200 | 055 | E | DEV | LND | 0 | E | E | EE21 | LUZ2 | E | LND |  |  |  |
| E3E0420 |  | R. Gear Motors - Techn. Eval./PO Spec |  | 74d | 2008-06-16 A | 2008-09-25 A | P3E04B FS+20d | 100% |  |  |  |  |  |  | E3E0420 | E3E0420 | 87D | E04 | 00 | 2KB2429 | 200 | 200 | 055 | E |  | LND | 0 | E | E | EE21 | LUZ2 | E | LND |  |  |  |
| E3E0430 |  | R. Gear Motors - Techn. Eval./Bid Tab | milestone | 0d | 2008-08-09 A | 2008-08-09 A | E3E0420 FF-10d | 100% |  |  |  |  |  |  | E3E0430 | E3E0430 | 87D | E04 | 00 | 2KB2429 | 200 | 200 | 055 | E |  | LND | 0 | E | E | EE21 | LUZ2 | E | LND |  |  |  |
| E3E0450 |  | R. Gear Motors - Vendor dwgs approved | milestone | 0d | 2008-11-21 A | 2008-11-21 A | P3E04D FF+20d | 100% |  |  |  |  |  |  | E3E0450 | E3E0450 | 87D | E04 | 00 | 2KB2429 | 200 | 200 | 400 | E |  | LND | 0 | E | E | EE21 | LUZ2 | E | LND |  |  |  |
| E3E0305 |  | E03 Distrib./Lighting Panel - Preparation BOQ f.OBCE |  | 10d | 2009-01-19 A | 2009-01-30 A | F2450 | 100% |  |  |  |  |  |  | E3E0305 | E3E0305 | 87E | E03 | 00 | 2EB6150 | 200 | 200 | 055 | E | DEV | LND | 0 | E | E | EE34 | LUZ2 | P | LND |  |  |  |
| E3E0310 |  | E03 Distrib./Lighting Panel - Techn. Spec. |  | 19d | 2010-04-12 A | 2010-05-06 A | E3E0305 | 100% |  |  |  | TAE [320 h] |  |  | E3E0310 | E3E0310 | 87E | E03 | 00 | 2EB6150 | 200 | 200 | 055 | E | DEV | LND | 0 | E | E | EE34 | LUZ2 | P | LND | 320,00 |  |  |
| E3E0335 |  | E03 Distrib./Lighting Panel - Preparation final BOQ |  | 15d | 2010-06-09 A | 2010-06-29 A | E3E0310 SS+40d, E3E0305 FS+200d | 100% |  |  |  |  |  |  | E3E0335 | E3E0335 | 87E | E03 | 00 | 2EB6150 | 200 | 200 | 055 | E | DEV | LND | 0 | E | E | EE34 | LUZ2 | E | LND |  |  |  |
| E3E0320 |  | E03 Distrib./Lighting Panel - Techn. Eval./PO Spec (E&I SUB) |  | 113d | 2010-07-09 A | 2010-12-15 A | P3E03B FS+40d | 100% |  |  |  | TAE [320 h] |  |  | E3E0320 | E3E0320 | 87E | E03 | 00 | 2EB6150 | 200 | 200 | 055 | E |  | CC | 0 | E | E | EE34 | LUZ2 | E | LND | 320,00 |  |  |
|  | J | **J Instrumentation** |  |  | 2009-08-17 | 2009-09-11 |  |  |  |  |  |  |  |  |  |  |  |  |  |  |  |  |  |  |  |  |  |  |  |  |  |  |  |  |  |  |
| E3J0606 |  | J06 DCS / SIS - Scope/Schedule/Spec. Defin. w. Client/Yokogawa |  | 5d | 2009-08-17 A | 2009-08-21 A | E3J0605 | 100% |  |  |  |  |  |  | E3J0606 | E3J0606 | 86B | J06 | 00 | 2JD9220 | 200 | 200 | 400 | P | DEV | LND | 0 | E | J | EJ33 | LUZ2 | I | LND |  | 999 |  |
| E3J0608 |  | J06 DCS / SIS - Alignment Meeting w. Client/Yokogawa - Scope definition |  | 5d | 2009-09-07 A | 2009-09-11 A | E3J0606 FS+10d | 100% |  |  |  |  |  |  | E3J0608 | E3J0608 | 86B | J06 | 00 | 2JD9220 | 200 | 200 | 400 | P | DEV | LND | 0 | E | J | EJ33 | LUZ2 | I | LND |  | 999 |  |
|  | M | **M Mechanical - Rotating Equipment** |  |  | 2008-02-25 | 2011-10-24 |  |  |  |  |  |  |  |  |  |  |  |  |  |  |  |  |  |  |  |  |  |  |  |  |  |  |  |  |  |  |
| F7220 |  | M01 Extruder Pck. - Prel.bid tab for PMT review |  | 5d | 2008-02-25 A | 2008-02-29 A | F7160 | 100% |  |  |  |  |  |  | F7220 | F7220 | 867 | M01 | 00 | 2DC8480 | 200 | 200 | 400 | P |  | LND | C2 | E | M | EM34 | LUZ2 | 1 | LND |  | DC | 3A |
| F6810 |  | M11 RA Gear Unit - Prel.Bid tab for PMT review |  | 5d | 2008-04-30 A | 2008-05-07 A | F6760 | 100% |  |  |  |  |  |  | F6810 | F6810 | 867 | M11 | 00 | 2KB4290 | 200 | 200 | 400 | P |  | LND | C2 | E | M | EM94 | LUZ2 | 1 | LND |  | DC | 3A |
| F7350 |  | M06 R. Tepid Pumps - Prel.Bid tab for PMT review |  | 5d | 2008-05-08 A | 2008-05-15 A | F7300 | 100% |  |  |  |  |  |  | F7350 | F7350 | 867 | M06 | 00 | 2PA6540 | 200 | 200 | 400 | P |  | LND | C2 | E | M | EM24 | LUZ2 | 1 | LND |  | DC |  |
| F7650 |  | M05 R. Quench Pumps- Prel.bid tab for PMT review |  | 5d | 2008-05-08 A | 2008-05-15 A | F7600 | 100% |  |  |  |  |  |  | F7650 | F7650 | 867 | M05 | 00 | 2PA6550 | 200 | 200 | 400 | P |  | LND | C2 | E | M | EM24 | LUZ2 | 1 | LND |  | DC |  |
| E3M0815 |  | M08 Teal/Donor Feed P. - Prel.Bid for PMT review | milestone | 0d | 2008-06-26 A | 2008-06-26 A | E3M0820 SS-2d | 100% |  |  |  |  |  |  | E3M0815 | E3M0815 | 867 | M08 | 00 | 2PA6690 | 200 | 200 | 055 | E |  | LND | 0 | E | M | EM24 | LUZ2 | I | LND |  |  |  |
| E3M1015 |  | M10 Catalyst Waste Pu. - Prel.Bid for PMT review | milestone | 0d | 2008-06-26 A | 2008-06-26 A | E3M1020 SS+5d | 100% |  |  |  |  |  |  | E3M1015 | E3M1015 | 867 | M10 | 00 | 2PA6690 | 200 | 200 | 055 | E |  | LND | 0 | E | M | EM24 | LUZ2 | 3 | LND |  |  |  |
| E3M1215 |  | M12 Rotary Feeder - Prel.Bid for PMT review | milestone | 0d | 2008-07-16 A | 2008-07-16 A | E3M1220 SS-3d | 100% |  |  |  |  |  |  | E3M1215 | E3M1215 | 867 | M12 | 00 | 2DC8940 | 200 | 200 | 055 | E |  | LND | 0 | E | M | EM94 | LUZ2 | 3 | LND |  |  |  |
| E3M0715 |  | M07 Catalyst Feed Pump - Prel.Bid for PMT review | milestone | 0d | 2008-07-31 A | 2008-07-31 A | E3M0720 SS-2d | 100% |  |  |  |  |  |  | E3M0715 | E3M0715 | 867 | M07 | 00 | 2PA6670 | 200 | 200 | 055 | E |  | LND | 0 | E | M | EM24 | LUZ2 | I | LND |  |  |  |
| E3M0915 |  | M09 Unloading Pumps - Prel.Bid for PMT review | milestone | 0d | 2008-10-07 A | 2008-10-07 A | E3M0920 SS-4d | 100% |  |  |  |  |  |  | E3M0915 | E3M0915 | 867 | M09 | 00 | 2PA6680 | 200 | 200 | 055 | E |  | LND | 0 | E | M | EM24 | LUZ2 | 3 | LND |  |  |  |
| E3M1510 |  | M15 Conds./BoosterP. - Inquiry Spec. |  | 12d | 2009-02-09 A | 2009-02-24 A | F1670 SS+90d | 100% |  |  |  |  |  |  | E3M1510 | E3M1510 | 867 | M15 | 00 | 2PA6720 | 200 | 200 | 055 | E | DEV | LND | 0 | E | M | EM93 | LUZ2 | 3 | LND |  |  |  |
| E3M1610 |  | M16 Instrument Air Compr. - Inquiry Spec. |  | 11d | 2009-02-09 A | 2009-02-23 A | F1670 SS+30d | 100% |  |  |  |  |  |  | E3M1610 | E3M1610 | 867 | M16 | 00 | 2KB4660 | 200 | 200 | 055 | E | DEV | LND | 0 | E | M | EM13 | LUZ2 | 3 | LND |  |  |  |
| E3M1615 |  | M16 Instrument Air Com - Prel.Bid for PMT review | milestone | 0d | 2009-07-23 A | 2009-07-23 A | E3M1620 SS-3d, E3M01A20 SS-3d | 100% |  |  |  |  |  |  | E3M1615 | E3M1615 | 867 | M16 | 00 | 2KB4660 | 200 | 200 | 055 | E |  | LND | 0 | E | M | EM14 | LUZ2 | 3 | LND |  |  |  |
| E3M1620 |  | M16 Instrument Air Compr. - Techn. Eval./PO Spec |  | 132d | 2009-08-14 A | 2010-02-22 A | P3M16B FS+110d | 100% |  |  |  | TAM [1280 h] |  |  | E3M1620 | E3M1620 | 867 | M16 | 00 | 2KB4660 | 200 | 200 | 055 | E |  | LND | 0 | E | M | EM14 | LUZ2 | 2 | LND | 1280,00 |  |  |
| E3M1515 |  | M15 Conds./BoosterP. - Prel.Bid for PMT review | milestone | 0d | 2009-09-30 A | 2009-09-30 A | E3M1520 SS-2d | 100% |  |  |  |  |  |  | E3M1515 | E3M1515 | 867 | M15 | 00 | 2PA6720 | 200 | 200 | 055 | E |  | LND | 0 | E | M | EM24 | LUZ2 | 3 | LND |  |  |  |
| E3M1520 |  | M15 Conds./BoosterP. - Techn. Eval./PO Spec |  | 112d | 2009-10-30 A | 2010-04-14 A | HEB20 FF, P3M15B FS+165d | 100% |  |  |  | TAM [800 h] |  |  | E3M1520 | E3M1520 | 867 | M15 | 00 | 2PA6720 | 200 | 200 | 055 | E |  | LND | 0 | E | M | EM94 | LUZ2 | 2 | LND | 800,00 |  |  |
| E3M1630 |  | M16 Instrument Air Compr -Techn. Eval./Bid Tab F | milestone | 0d | 2009-11-09 A | 2009-11-09 A | E3M1620 FF-25d, E3M01A20 FF-25d, E3M1615 SF | 100% |  |  |  |  |  |  | E3M1630 | E3M1630 | 867 | M16 | 00 | 2KB4660 | 200 | 200 | 055 | E |  | LND | 0 | E | M | EM14 | LUZ2 | 2 | LND |  |  |  |
| E3M1530 |  | M15 Conds./BoosterP. -Techn. Eval./Bid Tab F | milestone | 0d | 2010-02-03 A | 2010-02-03 A | E3M1515 SF, E3M1520 FF-6d | 100% |  |  |  |  |  |  | E3M1530 | E3M1530 | 867 | M15 | 00 | 2PA6720 | 200 | 200 | 055 | E |  | LND | 0 | E | M | EM94 | LUZ2 | 2 | LND |  |  |  |
| E3M1640 |  | M16 Instrument Air Compr. - 1st Review dwgs |  | 25d | 2010-03-24 A | 2010-04-29 A | P3M16L SS+22d | 100% |  |  |  | TAM [640 h] |  |  | E3M1640 | E3M1640 | 867 | M16 | 00 | 2KB4660 | 200 | 200 | 055 | E |  | LND | 0 | E | M | EM15 | LUZ2 | 3 | LND | 640,00 |  |  |
| E3M01A10 |  | M01A PCW Cooler - Inquiry Spec. |  | 14d | 2010-04-12 A | 2010-04-29 A | F1670 SS+30d | 100% |  |  |  |  |  |  | E3M01A10 | E3M01A10 | 867 | M01A | 00 | 2KB9850 | 200 | 200 | 055 | E | DEV | LND | 0 | E | M | EM13 | LUZ2 | 3 | LND |  |  |  |
| E3M1650 |  | M16 Instrument Air Compr - Vendor dwgs approved | milestone | 0d | 2010-04-29 A | 2010-04-29 A | E3M1640 FF | 100% |  |  |  |  | 66,115.2 | 66,115.2 | E3M1650 | E3M1650 | 867 | M16 | 00 | 2KB4660 | 200 | 200 | 055 | E | DFA | LND | 0 | E | M | EM15 | LUZ2 | 3 | LND |  |  |  |
| E3M1540 |  | M15 Conds./BoosterP. - 1st Review dwgs |  | 7d | 2010-05-07 A | 2010-05-18 A | P3M15D FF+30d, HEB50 FF | 100% |  |  |  | TAM [200 h] |  |  | E3M1540 | E3M1540 | 867 | M15 | 00 | 2PA6720 | 200 | 200 | 055 | E |  | LND | 0 | E | M | EM25 | LUZ2 | 3 | LND | 200,00 |  |  |
| E3M1550 |  | M15 Conds./BoosterP. - Vendor dwgs approved | milestone | 0d | 2010-05-18 A | 2010-05-18 A | E3M1540 FF | 100% |  |  |  |  | 20,400 | 20,400 | E3M1550 | E3M1550 | 867 | M15 | 00 | 2PA6720 | 200 | 200 | 055 | E | DFA | LND | 0 | E | M | EM25 | LUZ2 | 3 | LND |  |  |  |
| E3M1660 |  | M16 Instrument Air Compr. - 2nd Review dwgs |  | 36d | 2010-05-21 A | 2010-07-12 A | P3M16D FS+60d | 100% |  |  |  | TAM [400 h] |  |  | E3M1660 | E3M1660 | 867 | M16 | 00 | 2KB4660 | 200 | 200 | 055 | E |  | LND | 0 | E | M | EM15 | LUZ2 | 3 | LND | 400,00 |  |  |
| E3M01A20 |  | M01A PCW Cooler - Techn. Eval./PO Spec |  | 29d | 2010-06-07 A | 2010-07-15 A | P3M01AB FS+20d | 100% |  |  |  |  |  |  | E3M01A20 | E3M01A20 | 867 | M01A | 00 | 2KB9850 | 200 | 200 | 055 | E |  | LND | 0 | E | M | EM14 | LUZ2 | 2 | LND |  |  |  |
| E3M1560 |  | M15 Conds./BoosterP. - 2nd Review dwgs |  | 30d | 2010-06-10 A | 2010-07-21 A | E3B100 FF, P3M15L SS+55d | 100% |  |  |  | TAM [400 h] |  |  | E3M1560 | E3M1560 | 867 | M15 | 00 | 2PA6720 | 200 | 200 | 055 | E |  | LND | 0 | E | M | EM25 | LUZ2 | 3 | LND | 400,00 |  |  |
| E3M1675 |  | M16 Instrument Air Compr. - Review Instr. Data Sheets / PLC / JB |  | 30d | 2010-06-25 A | 2010-08-05 A | E3M1660 SS+24d | 100% |  |  |  |  |  |  | E3M1675 | E3M1675 | 867 | M16 | 00 | 2KB4660 | 200 | 200 | 055 | E |  | LND | 0 | E | M | EM15 | LUZ2 | 3 | LND |  |  |  |
| E3M01A40 |  | M01A PCW Cooler - 1st Review dwgs |  | 15d | 2010-08-23 A | 2010-09-10 A | P3M01AL SS+35d | 100% |  |  |  |  |  |  | E3M01A40 | E3M01A40 | 867 | M01A | 00 | 2KB9850 | 200 | 200 | 055 | E |  | LND | 0 | E | M | EM15 | LUZ2 | 3 | LND |  |  |  |
| E3M01A50 |  | M01A PCW Cooler - Vendor dwgs approved | milestone | 0d | 2010-09-10 A | 2010-09-10 A | E3M01A40 FF | 100% |  |  |  |  |  |  | E3M01A50 | E3M01A50 | 867 | M01A | 00 | 2KB9850 | 200 | 200 | 055 | E | DFA | LND | 0 | E | M | EM15 | LUZ2 | 3 | LND |  |  |  |
| E3M01A60 |  | M01A PCW Cooler - 2nd Review dwgs |  | 21d | 2010-10-15 A | 2010-11-12 A | P3M01AD FS+65d | 100% |  |  |  |  |  |  | E3M01A60 | E3M01A60 | 867 | M01A | 00 | 2KB9850 | 200 | 200 | 055 | E |  | LND | 0 | E | M | EM15 | LUZ2 | 3 | LND |  |  |  |
| E3M1710 |  | M17 Chiller Unit - Inquiry Spec. (new in LINDE scope) |  | 12d | 2010-10-18 A | 2010-11-02 A | F1670 SS+30d | 100% |  |  |  |  |  |  | E3M1710 | E3M1710 | 867 | M17 | 00 | 2KB9890 | 200 | 200 | 055 | E | DEV | LND | 0 | E | M | EM13 | LUZ2 | 3 | LND |  |  |  |
| E3M1720 |  | M17 Chiller Unit - Techn. Eval./PO Spec |  | 142d | 2011-01-06 A | 2011-07-22 A | P3M17B FS+40d | 100% |  |  |  |  |  |  | E3M1720 | E3M1720 | 867 | M17 | 00 | 2KB9890 | 200 | 200 | 055 | E |  | LND | 0 | E | M | EM14 | LUZ2 | 2 | LND |  |  |  |
| E3M1730 |  | M17 Chiller Unit -Techn. Eval./Bid Tab F | milestone | 0d | 2011-05-23 A | 2011-05-23 A | E3M1720 FF-10d | 100% |  |  |  |  |  |  | E3M1730 | E3M1730 | 867 | M17 | 00 | 2KB9890 | 200 | 200 | 055 | E |  | LND | 0 | E | M | EM14 | LUZ2 | 2 | LND |  |  |  |
| E3M1740 |  | M17 Chiller Unit - 1st Review dwgs |  | 15d | 2011-08-17 A | 2011-09-06 | P3M17L SS+25d |  | 4d | 216d | 0d |  |  |  | E3M1740 | E3M1740 | 867 | M17 | 00 | 2KB9890 | 200 | 200 | 055 | E |  | LND | 0 | E | M | EM15 | LUZ2 | 3 | LND |  |  |  |
| E3M1750 |  | M17 Chiller Unit - Vendor dwgs approved | milestone | 0d | 2011-09-06 | 2011-09-06 | E3M1740 FF |  |  | 216d | 0d |  |  |  | E3M1750 | E3M1750 | 867 | M17 | 00 | 2KB9890 | 200 | 200 | 055 | E | DFA | LND | 0 | E | M | EM15 | LUZ2 | 3 | LND |  |  |  |
| E3M1760 |  | M17 Chiller Unit - 2nd Review dwgs |  | 15d | 2011-10-04 | 2011-10-24 | P3M17D FS+50d |  |  | 183d | 18d |  |  |  | E3M1760 | E3M1760 | 867 | M17 | 00 | 2KB9890 | 200 | 200 | 055 | E |  | LND | 0 | E | M | EM15 | LUZ2 | 3 | LND |  |  |  |

Notes:
- E3E0450: Expenses: 900A 0
- E3M1650: Expenses: 900A 66115.2
- E3M1550: Expenses: 900A 20400

| ID | WBS | Activity | Type | Duration | Start | Finish | Predecessors | Complete | Calendar | UDF_SAVE ACTID | UDF_SAVE ACT ID | Department | Type of Work | Constr. Area | Inquiry/Order No | PMT-Area | PMT-Schedule Org | PMT-Discipline | PMT-Phase | PMT-Respons. | Zeigen/n. Zeigen | WBS Phase | WBS Discipline | WBS Type of Work | WBS Objects | IMS | UPT | PMT-Doc. Type | Pro Unit/DocCode | PMT-Stage | UDF_Actictity Name (Russia) | Russia WBS Discipline (Russia) | Russia Construction Area | Russia WBS Phase |
| --- | --- | --- | --- | --- | --- | --- | --- | --- | --- | --- | --- | --- | --- | --- | --- | --- | --- | --- | --- | --- | --- | --- | --- | --- | --- | --- | --- | --- | --- | --- | --- | --- | --- | --- |
|  | N | **N Structural Steel** |  |  | 2008-03-03 | 2010-06-30 |  |  |  |  |  |  |  |  |  |  |  |  |  |  |  |  |  |  |  |  |  |  |  |  |  |  |  |  |
| EN15N0340 |  | N01 Structural Steel Fab - CAD Model/Concepts |  | 126d | 2008-03-03 A | 2008-08-29 A | EN151201 FF | 100% |  | EN15N0340 | EN15N0340 | 87B | N01 | 00 | 2M00020 | 200 | 200 | 055 | E | LND | 0 | E | N | EN15 | LUZ2 | de | LND |  |  |  |  |  |  |  |
| E3N0110 |  | N01 Structural Steel Fab - Inquiry Spec. |  | 18d | 2009-05-18 A | 2009-06-12 A | EN21120110 SF, EN21130105 SS | 100% |  | E3N0110 | E3N0110 | 87B | N01 | 00 | 2M00020 | 200 | 200 | 055 | E | LND | 0 | E | N | EM13 | LUZ2 | 3 | LND | DEV |  |  |  |  |  |  |
| E3N0120 |  | N01 Structural Steel Fab - Techn. Eval./PO Spec |  | 171d | 2009-10-22 A | 2010-06-30 A | P3N01B FS+85d | 100% |  | E3N0120 | E3N0120 | 87B | N01 | 00 | 2M00020 | 200 | 200 | 055 | E | LND | 0 | E | N | EM14 | LUZ2 | 3 | LND |  |  |  |  |  |  |  |
| E3N0130 |  | N01 Structural Steel Fab -Techn. Eval./Bid Tab F | milestone | 0d | 2009-12-18 A | 2009-12-18 A | P3N01C FF-10d | 100% |  | E3N0130 | E3N0130 | 87B | N01 | 00 | 2M00020 | 200 | 200 | 055 | E | LND | 0 | E | N | EM14 | LUZ2 | 2 | LND |  |  |  |  |  |  |  |
|  | R | **R Piping** |  |  |  |  |  |  |  |  |  |  |  |  |  |  |  |  |  |  |  |  |  |  |  |  |  |  |  |  |  |  |  |  |
|  | S | **S Safety & Environment** |  |  | 2008-12-16 | 2009-09-02 |  |  |  |  |  |  |  |  |  |  |  |  |  |  |  |  |  |  |  |  |  |  |  |  |  |  |  |  |
| E3S0115 |  | S01 Safety Relief Val - Prel.Bid for PMT review | milestone | 0d | 2008-12-16 A | 2008-12-16 A | E3S0120 SS-1d | 100% |  | E3S0115 | E3S0115 | 871 | S01 | 00 | 2SI1760 | 200 | 200 | 080 | E | LND | 0 | E | S | ES24 | LUZ2 | SA | LND |  |  |  |  |  |  |  |
| E3S0215 |  | S02 Rupture Disks - Prel.Bid for PMT review | milestone | 0d | 2009-01-28 A | 2009-01-28 A | E3S0220 SS-7d | 100% |  | E3S0215 | E3S0215 | 871 | S02 | 00 | 2SI1750 | 200 | 200 | 080 | E | LND | 0 | E | S | ES24 | LUZ2 | 1 | LND |  |  |  |  |  |  |  |
| E3S0515 |  | S05 Gas Exting. Syst. - Prel.Bid for PMT review | milestone | 0d | 2009-09-02 A | 2009-09-02 A | E3S0520 SS-7d | 100% |  | E3S0515 | E3S0515 | 871 | S05 | 00 | 2SI1770 | 200 | 200 | 080 | E | LND | 0 | E | S | ES24 | LUZ2 | 1 | LND |  |  |  |  |  |  |  |
| E3S0615 |  | S06 Sprinkler System - Prel.Bid for PMT review | milestone | 0d | 2009-09-02 A | 2009-09-02 A | E3S0620 SS-8d | 100% |  | E3S0615 | E3S0615 | 871 | S06 | 00 | 2SI1740 | 200 | 200 | 080 | E | LND | 0 | E | S | ES24 | LUZ2 | 1 | LND |  |  |  |  |  |  |  |
| E3S0715 |  | S07 Deluge System - Prel.Bid for PMT review | milestone | 0d | 2009-09-02 A | 2009-09-02 A | E3S0720 SS-7d | 100% |  | E3S0715 | E3S0715 | 871 | S07 | 00 | 2SI1730 | 200 | 200 | 080 | E | LND | 0 | E | S | ES24 | LUZ2 | 1 | LND |  |  |  |  |  |  |  |
|  | U | **U Package Units** |  |  | 2008-04-29 | 2008-12-12 |  |  |  |  |  |  |  |  |  |  |  |  |  |  |  |  |  |  |  |  |  |  |  |  |  |  |  |  |
| F8060 |  | PU02 Add.Feed Syst.- Prel.Bid tab for PMT review |  | 3d | 2008-04-29 A | 2008-05-02 A | F8010 | 100% |  | F8060 | F8060 | 869 | PU02 | 00 | 2DC9820 | 200 | 200 | 400 | P | LND | C2 | E | U | EU24 | LUZ2 | 1 | LND |  | DC | 3A |  |  |  |  |
| F8260 |  | PU12 Prop.Rec.Unit - Prel.Bid tab for PMT review |  | 5d | 2008-05-09 A | 2008-05-16 A | F8210 | 100% |  | F8260 | F8260 | 869 | PU12 | 00 | 2KB4240 | 200 | 200 | 400 | P | LND | C2 | E | U | EU94 | LUZ2 | 1 | LND |  | DC | 3A |  |  |  |  |
| F10230 |  | PU06 Bagging Syste - Prel.Bid tab for PMT review |  | 4d | 2008-07-08 A | 2008-07-11 A | E3U0620 SS | 100% |  | F10230 | F10230 | 869 | PU06 | 00 | 2DC9010 | 200 | 200 | 400 | P | LND | C2 | E | U | EU34 | LUZ2 | 1 | LND |  | DC | 3A |  |  |  |  |
| P3U07F |  | PU07 Packaging Sys - Prel.Bid tab for PMT review |  | 4d | 2008-07-08 A | 2008-07-11 A | E3U0720 SS | 100% |  | P3U07F | P3U07F | 869 | PU07 | 00 | 2DC9020 | 200 | 200 | 400 | P | LND | C2 | E | U | EU34 | LUZ2 | P | LND |  | DC | 3A |  |  |  |  |
| F10460 |  | PU10 Convey. Syst. - Prel.Bid tab to PMT review |  | 4d | 2008-07-11 A | 2008-07-16 A | E3U1020 SS | 100% |  | F10460 | F10460 | 869 | PU10 | 00 | 2DC8990 | 200 | 200 | 400 | P | LND | C2 | E | U | EU14 | LUZ2 | 1 | LND |  | DC | 3A |  |  |  |  |
| E3U1515 |  | PU15 Reactor Seal Oil - Prel.Bid for PMT review | milestone | 0d | 2008-08-28 A | 2008-08-28 A | E3U1520 SS-5d | 100% |  | E3U1515 | E3U1515 | 869 | PU15 | 00 | 2DC8910 | 200 | 200 | 055 | E | LND | 0 | E | U | EU94 | LUZ2 | 2 | LND |  |  |  |  |  |  |  |
| E3U2215 |  | PU22 Vacuum System - Prel.Bid for PMT review | milestone | 0d | 2008-10-10 A | 2008-10-10 A | E3U2220 SS-3d | 100% |  | E3U2215 | E3U2215 | 869 | PU22 | 00 | 2DC9170 | 200 | 200 | 055 | E | LND | 0 | E | U | EU94 | LUZ2 | 3 | LND |  |  |  |  |  |  |  |
| E3U0515 |  | PU05 Big Bag L. Stati - Prel.Bid for PMT review | milestone | 0d | 2008-12-12 A | 2008-12-12 A | E3U0520 SS+10d | 100% |  | E3U0515 | E3U0515 | 869 | PU05 | 00 | 2DC9640 | 200 | 200 | 055 | E | LND | 0 | E | U | EU94 | LUZ2 | 1 | LND |  |  |  |  |  |  |  |
|  | LUTZ | **LUTZ Construction General** |  |  | 2008-02-01 | 2011-04-30 |  |  |  |  |  |  |  |  |  |  |  |  |  |  |  |  |  |  |  |  |  |  |  |  |  |  |  |  |
|  | C | **C Civil** |  |  | 2008-02-01 | 2011-04-30 |  |  |  |  |  |  |  |  |  |  |  |  |  |  |  |  |  |  |  |  |  |  |  |  |  |  |  |  |
| IMS-E-000120 |  | Civil, Structural & Architectural Design | level of effort | 979d | 2008-02-01 A | 2011-04-30 A | F1470 SS, F8820 SS, F8860 SS | 100% | TB26 - 3 - Construct-normal * | IMS-E-000120 | IMS-E-000120 | 934 |  | 00 |  | 200 | 200 |  | C | LND |  | E | C | XE00 | LUTZ | de | IMS |  | 91 |  | Монтаж подстанции | E | 00 | E |

| ID | WBS | Activity | Type | Duration | Start | Finish | Predecessors | Complete | UDF_SAVE ACTID | UDF_SAVE ACT ID | Department | Constr. Area | PMT-Area | PMT-Schedule Org | PMT-Discipline | PMT-Phase | PMT-Respons. | Zeigen/n. Zeigen | WBS Phase | WBS Discipline | WBS Type of Work | WBS Objects | IMS | UPT | Type of Work | Pro Unit/DocCode | Inquiry/Order No | PMT-Stage |
| --- | --- | --- | --- | --- | --- | --- | --- | --- | --- | --- | --- | --- | --- | --- | --- | --- | --- | --- | --- | --- | --- | --- | --- | --- | --- | --- | --- | --- |
|  | 0000 | **0000 Generals - all CA's** |  |  | 2008-07-21 | 2011-04-21 |  |  |  |  |  |  |  |  |  |  |  |  |  |  |  |  |  |  |  |  |  |  |
|  | B | **B Mechanical - Stationary Equipment** |  |  | 2008-07-21 | 2010-11-19 |  |  |  |  |  |  |  |  |  |  |  |  |  |  |  |  |  |  |  |  |  |  |
| HEB20 |  | Remaining Eqpt PO - Techn. Eval./PO Spec | level of effort | 551d | 2008-07-21 A | 2010-09-29 A | E3U1520 SS, E3A0120 SS, E3A1120 SS, E3M1020 SS, E3A0620 SS, E3A02A20 SS, E3M1620 SS, E3U0720 SS, E3U0620 SS, E3M0820 SS, E3M0920 SS, E3M01A20 SS, E3A06A20 SS | 100% | HEB20 | HEB20 | 869 | 00 | 200 | 200 | 055 | E | LND | L2 | E | B | EB14 | 0000 | 2 | LND |  |  |  |  |
| HEB50 |  | Remaining Eqpt PO - Vendor Dwgs approved | level of effort | 295d | 2009-09-21 A | 2010-11-19 A | E3A0640 SS, E3M1640 SS, E3A0140 SS, E3A02A40 SS, E3A06A40 SS, E3A1140 SS, E3M0940 SS, E3U0740 SS, E3U1540 SS | 100% | HEB50 | HEB50 | 869 | 00 | 200 | 200 | 055 | E | LND | L2 | E | B | EB14 | 0000 | 3 | LND | A17 |  |  |  |
|  | C | **C Civil** |  |  | 2009-08-24 | 2011-04-21 |  |  |  |  |  |  |  |  |  |  |  |  |  |  |  |  |  |  |  |  |  |  |
| HEC45B |  | Building Layout Dwgs AFC | level of effort | 301d | 2009-08-24 A | 2010-10-29 A | EC45314005 SS, EC45161005 SS, EC45312005 SS, EC45170005 FF, EC45311005 SS | 100% | HEC45B | HEC45B | 87A | 00 | 200 |  |  |  | CDC | L2 | E | C | EC15 | 0000 | ar | LND |  |  |  |  |
| HEC15 |  | Piling Dwgs AFC | level of effort | 384d | 2009-09-07 A | 2011-03-14 A | EC153110 SS, EC155101 SS, EC151610 SS, EC155402 SS, EC155401 SS | 100% | HEC15 | HEC15 | 87A | 00 | 200 |  |  |  | CDC | L2 | E | C | EC15 | 0000 | PI | LND |  |  |  |  |
| HEC48B |  | Formw./Reinf Dwgs Bldg Foundations AFC | level of effort | 215d | 2009-09-21 A | 2010-07-29 A | EC48161003 SS, EC48312003 SS, EC48314003 SS, EC28311003 SS, EC48171003 SS | 100% | HEC48B | HEC48B | 87A | 00 | 200 |  |  |  | CDC | L2 | E | C | EC15 | 0000 | ar | LND |  |  |  |  |
| HEC48P |  | Precast Dwgs Buildings AFC | level of effort | 264d | 2009-09-28 A | 2010-10-13 A | EC48161007 SS, EC48161006 SS, EC48312006 FF, EC48171004 SS, EC48312004 SS, EC48312008 FF, EC48161004 SS, EC48161008 SS, EC28311009 FF, EC28311004 SS | 100% | HEC48P | HEC48P | 87A | 00 | 200 |  |  |  | CDC | L2 | E | C | EC15 | 0000 | PRE | LND |  |  |  |  |
| HEC48S |  | Formw./Reinf Dwgs Bldg/Slabs/Struct. AFC | level of effort | 306d | 2009-10-05 A | 2010-12-20 A | EC28311007 SS, EC48314005 SS, EC48171005 SS, EC48161005 SS, EC28311005 SS, EC48312005 SS | 100% | HEC48S | HEC48S | 87A | 00 | 200 |  |  |  | CDC | L2 | E | C | EC15 | 0000 | ar | LND |  |  |  |  |
| HEC50 |  | Architectural Detail Dwgs Bldg AFC | level of effort | 254d | 2009-11-24 A | 2010-11-25 A | EC501610 SS, EC503120 SS, EC503110 SS | 100% | HEC50 | HEC50 | 87A | 00 | 200 |  |  |  | CDC | L2 | E | C | EC15 | 0000 | ar | LND |  |  |  |  |
| HEC45C |  | Civil Layout Dwgs AFC | level of effort | 337d | 2009-12-22 A | 2011-04-21 A | EC45550105 SS, EC45560105 SS, EC45170705 SS, EC45550205 SS, EC45151105 SS, EC45540205 SS, EC45120105 SS, EC45170805 SS, EC45130105 SS, EC45540105 SS | 100% | HEC45C | HEC45C | 87A | 00 | 200 |  |  |  | CDC | L2 | E | C | EC15 | 0000 | cq | LND |  |  |  |  |
| EC15120010 |  | Overall Upstream - Piling Design AFC | level of effort | 299d | 2010-01-11 A | 2011-03-14 A | EC151010 FF, EC151710 FF, EC151205 SS, EC151221 FF, EC151110 SS, EC155102 SS, EC151204 FF, EC151510 FF, EC151222 FF, EC151201 SS, EC155301 FF | 100% | EC15120010 | EC15120010 | 87A | 00 | 200 | 200 |  | E | IPR |  | E | C | EC15 | 0000 | PI | LND |  | 9600C16 |  |  |
| HEC28 |  | Formw./Reinf Dwgs Equipm. Foundations AFC | level of effort | 102d | 2010-03-29 A | 2010-08-23 A | EC28171010 SS, EC281330 SS | 100% | HEC28 | HEC28 | 87A | 00 | 200 |  |  |  | CDC | L2 | E | C | EC15 | 0000 | cq | LND |  |  |  |  |
| HEC60 |  | Paving Dwgs AFC | level of effort | 147d | 2010-05-14 A | 2010-12-08 A | EC601400 SS, EC601500 SS, EC601200 SS, EC601600 SS, EC601300 SS, EC601700 SS | 100% | HEC60 | HEC60 | 87A | 00 | 200 |  |  |  | CDC | L2 | E | C | EC15 | 0000 | de | LND |  |  |  |  |
|  | H | **H HVAC** |  |  | 2009-08-31 | 2010-11-22 |  |  |  |  |  |  |  |  |  |  |  |  |  |  |  |  |  |  |  |  |  |  |
| HEH30 |  | HVAC Layouts Dwgs AFC | level of effort | 311d | 2009-08-31 A | 2010-11-22 A | EH30161005 SS, EH30171005 SS, EH30312005 FF, EH30314005 SS | 100% | HEH30 | HEH30 | 87C | 00 | 200 | 200 | 035 | E | LND | L2 | E | H | EH30 | 0000 | OTH | LND |  |  |  |  |
| HEH24 |  | HVAC Wall/Floor opening Details | level of effort | 186d | 2010-03-01 A | 2010-11-22 A | EH241610 SF, EH243140 FF | 100% | HEH24 | HEH24 | 87C | 00 | 200 | 200 | 035 | E | LND | L2 | E | H | EH30 | 0000 | OTH | LND |  |  |  |  |
| HEH12 |  | HVAC Final Loads for Civil/Structural | level of effort | 125d | 2010-05-31 A | 2010-11-22 A | EH053140 FF, EH053110, EH051222 | 100% | HEH12 | HEH12 | 87C | 00 | 200 | 200 | 035 | E | LND | L2 | E | H | EH30 | 0000 | OTH | LND |  |  |  |  |
|  | R | **R Piping** |  |  | 2009-11-11 | 2010-02-05 |  |  |  |  |  |  |  |  |  |  |  |  |  |  |  |  |  |  |  |  |  |  |
| HER19 |  | Final Loads for Civil/Structural | level of effort | 58d | 2009-11-11 A | 2010-02-05 A | ER193140, ER193120, ER193110, ER193130, ER191201 SS | 100% | HER19 | HER19 | 873 | 00 | 200 | 200 | 035 | E | LND | L2 | E | R | ER19 | 0000 | de | LND |  |  |  |  |
|  | 1110 | **1110 Offgas Compressor Building - CA11** |  |  | 2008-02-29 | 2008-03-07 |  |  |  |  |  |  |  |  |  |  |  |  |  |  |  |  |  |  |  |  |  |  |
|  | M | **M Mechanical - Rotating Equipment** |  |  | 2008-02-29 | 2008-03-07 |  |  |  |  |  |  |  |  |  |  |  |  |  |  |  |  |  |  |  |  |  |  |
| F6410 |  | M03 Offgas Compr. - Prel.bid tab for PMT review |  | 6d | 2008-02-29 A | 2008-03-07 A | F6360 | 100% | F6410 | F6410 | 867 | 00 | 200 | 200 | 400 | P | LND | C2 | E | M | EM14 | 1110 | 1 | LND | M03 | DC | 2DC8460 | 3A |

Notes:
- HEB20: UDF_Actictity Name (Russia): Оставшиеся заказы на поставку оборудования - технический анализ/спецификации заказов на поставку
- HEB50: UDF_Actictity Name (Russia): Оставшиеся заказы на поставку оборудования - Утверждение чертежей поставщиков
- HEC45B: UDF_Actictity Name (Russia): Здания, компоновочные чертежи, AFC
- HEC15: UDF_Actictity Name (Russia): Чертежи свай, AFC
- HEC48B: UDF_Actictity Name (Russia): Здания, чертежи опалубки/армирования, фундаменты, AFC
- HEC48P: UDF_Actictity Name (Russia): Здания, чертежи сборных конструкций, AFC
- HEC48S: UDF_Actictity Name (Russia): Чертежи опалубки/армирования, перекрытия/конструкции зданий, AFC
- HEC50: UDF_Actictity Name (Russia): Здания, детальные архитектурные чертежи, AFC
- HEC45C: UDF_Actictity Name (Russia): Общестроительные компоновочные чертежи, AFC
- EC15120010: P3 Activity Log Info: incl. Catch Basin and Pulling Pits
- HEC28: UDF_Actictity Name (Russia): Чертежи опалубки/армирования, фундаменты оборудования, AFC
- HEC60: UDF_Actictity Name (Russia): Чертежи дорожных покрытий, AFC
- HEH30: UDF_Actictity Name (Russia): ОВКВ, компоновочные чертежи, AFC
- HEH24: UDF_Actictity Name (Russia): ОВКВ, узлы проемов в стенах/полах
- HEH12: UDF_Actictity Name (Russia): ОВКВ, окончательные нагрузки по общестроительной части/конструкциям
- HER19: UDF_Actictity Name (Russia): Окончательные нагрузки по общестроительной части/конструкциям

| ID | WBS | Activity | Type | Duration | Start | Finish | Predecessors | Complete | UDF_SAVE ACTID | UDF_SAVE ACT ID | Department | Type of Work | Constr. Area | Pro Unit/DocCode | Inquiry/Order No | PMT-Area | PMT-Schedule Org | PMT-Discipline | PMT-Phase | PMT-Stage | PMT-Respons. | Zeigen/n. Zeigen | WBS Phase | WBS Discipline | WBS Type of Work | WBS Objects | IMS | UPT |
| --- | --- | --- | --- | --- | --- | --- | --- | --- | --- | --- | --- | --- | --- | --- | --- | --- | --- | --- | --- | --- | --- | --- | --- | --- | --- | --- | --- | --- |
|  | 1232 | **1232 Recycle Gas Compressor - CA12** |  |  | 2008-02-19 | 2008-02-26 |  |  |  |  |  |  |  |  |  |  |  |  |  |  |  |  |  |  |  |  |  |  |
|  | M | **M Mechanical - Rotating Equipment** |  |  | 2008-02-19 | 2008-02-26 |  |  |  |  |  |  |  |  |  |  |  |  |  |  |  |  |  |  |  |  |  |  |
| F6210 |  | M02 Recycle Gas C. - Prel.bid tab for PMT review |  | 6d | 2008-02-19 A | 2008-02-26 A | F6160 | 100% | F6210 | F6210 | 867 | M02 | 00 | DC | 2DC8490 | 200 | 200 | 400 | P | 3A | LND | C2 | E | M | EM14 | 1232 | 1 | LND |
|  | 1233 | **1233 Bleed Booster Compressor - CA12** |  |  | 2008-06-24 | 2008-06-27 |  |  |  |  |  |  |  |  |  |  |  |  |  |  |  |  |  |  |  |  |  |  |
|  | M | **M Mechanical - Rotating Equipment** |  |  | 2008-06-24 | 2008-06-27 |  |  |  |  |  |  |  |  |  |  |  |  |  |  |  |  |  |  |  |  |  |  |
| F6610 |  | M04 GasBleedCompr. - Prel.bid tab for PMT review |  | 4d | 2008-06-24 A | 2008-06-27 A | F6560 | 100% | F6610 | F6610 | 867 | M04 | 00 | DC | 2KB4360 | 200 | 200 | 400 | P | 3A | LND | C2 | E | M | EM14 | 1233 | 1 | LND |
|  | 0F | **0F FEED Phase All Areas** |  |  | 2007-12-10 | 2011-05-25 |  |  |  |  |  |  |  |  |  |  |  |  |  |  |  |  |  |  |  |  |  |  |
|  | LUZ2 | **LUZ2 General ( )** |  |  | 2007-12-10 | 2011-05-25 |  |  |  |  |  |  |  |  |  |  |  |  |  |  |  |  |  |  |  |  |  |  |
|  | 0B | **0B General Activities** |  |  | 2007-12-10 | 2008-10-30 |  |  |  |  |  |  |  |  |  |  |  |  |  |  |  |  |  |  |  |  |  |  |
| F3090 |  | FEED - Process related- |  | 137d | 2007-12-10 A | 2008-06-30 A | F3370, F2760 SS | 100% | F3090 | F3090 | 007 |  | 0F | 91 |  | 200 | 200 | 002 | F | 3A | LND |  | E | 0B | 0000 | LUZ2 | 00 | LND |
| F3130 |  | FEED - Layout related- |  | 176d | 2008-02-21 A | 2008-10-30 A | F2760 | 100% | F3130 | F3130 | 007 |  | 0F | 91 |  | 200 | 200 | 002 | F | 3A | LND |  | E | 0B | 0000 | LUZ2 | PI | LND |
|  | A | **A Project Management** |  |  | 2007-12-10 | 2008-11-07 |  |  |  |  |  |  |  |  |  |  |  |  |  |  |  |  |  |  |  |  |  |  |
| F1000 |  | Front End Engineering Design (FEED) |  | 181d | 2007-12-10 A | 2008-08-29 A | FCO004 FF, FCO010 FF, AD1230 FF, F2350 FF, FCO002 FF, FCO003 FF, FCO009 FF, FCO012 FF, FCO007 FF, F2760 SS, FCO005 FF, FCO006 FF, F2140 FF | 100% | F1000 | F1000 | 916 |  | 0F |  | PP | 200 | 200 | 001 | F | 3A | LND | 1 | E | A | 0000 | LUZ2 | 1 | LND |
| F1010 |  | Project Execution Plan -FEED |  | 57d | 2007-12-10 A | 2008-03-04 A | F1000 SS | 100% | F1010 | F1010 | 915 | AA | 0F |  |  | 200 | 200 | 001 | F | 3A | LND | 1 | E | A | 0000 | LUZ2 | 1 | LND |
| F1030 |  | Project Procederes Manual |  | 57d | 2007-12-10 A | 2008-03-04 A | F1000 SS | 100% | F1030 | F1030 | 915 | AA | 0F |  |  | 200 | 200 | 001 | F | 3A | LND | 1 | E | A | 0000 | LUZ2 | 1 | LND |
| F1090 |  | Change Management Program |  | 136d | 2007-12-10 A | 2008-06-27 A | F1000 SS | 100% | F1090 | F1090 | 956 |  | 0F |  |  | 200 | 200 | 001 | F | 3A | LND | 1 | E | A | 0000 | LUZ2 | 1 | LND |
| F1130 |  | FEED Schedule |  | 53d | 2007-12-10 A | 2008-02-27 A | F1000 SS | 100% | F1130 | F1130 | 932 |  | 0F |  |  | 200 | 200 |  | F | 3A | LND | 1 | E | A | 0000 | LUZ2 | 1 | LND |
| F2740 |  | RFQ's commercial part |  | 148d | 2007-12-20 A | 2008-07-25 A | F1670 FF, F1650 FF | 100% | F2740 | F2740 | 860 |  | 0F |  |  | 200 |  | 400 | F | 3A | LND | 1 | E | A | 0000 | LUZ2 | 1 | LND |
| F1170 |  | Work Break Down Structure |  | 49d | 2008-01-11 A | 2008-03-19 A | F1130 SS | 100% | F1170 | F1170 | 932 |  | 0F |  |  | 200 | 200 | 300 | F | 3A | LND | 1 | E | A | 0000 | LUZ2 | 1 | LND |
| F3850 |  | Long Lead Equipment List - PMT | milestone | 0d | 2008-01-12 A | 2008-01-12 A | F2680 FF | 100% | F3850 | F3850 | 860 |  | 0F |  |  | 200 |  |  | F | 3A | PMT | 1 | E | A | 0000 | LUZ2 | PI | LND |
| F2030 |  | Long Lead Equipment List |  | 10d | 2008-01-14 A | 2008-01-25 A | F2680, F1000 SS | 100% | F2030 | F2030 | 860 |  | 0F |  |  | 200 |  |  | F | 3A | LND | 1 | E | A | 0000 | LUZ2 | 1 | LND |
| F2060 |  | Shipping/Logistics Study |  | 116d | 2008-01-28 A | 2008-07-11 A | F2760 | 100% | F2060 | F2060 | 860 |  | 0F |  |  | 200 |  | 400 | F | 3A | LND | 1 | E | A | 0000 | LUZ2 | 1 | LND |
| FCO006 |  | CO-06 Copyable Reactor & Extrusion Layout |  | 126d | 2008-02-01 A | 2008-07-31 A | F2760 | 100% | FCO006 | FCO006 | 916 | AA | 0F |  |  | 200 | 200 | 001 | F | 3A | LND | 1 | E | A | 0000 | LUZ2 |  | LND |
| F2990 |  | Open Book FEED -cost estimate- |  | 90d | 2008-02-20 A | 2008-06-30 A | F2760 | 100% | F2990 | F2990 | L4 |  | 0F |  |  | 200 | 200 |  | F |  | LND | 3 | E | A | 0000 | LUZ2 | E | LND |
| F2750 |  | Bid Evaluations |  | 176d | 2008-02-21 A | 2008-10-30 A | F2310 FF, F2740 FF+19d | 100% | F2750 | F2750 | 860 |  | 0F |  |  | 200 |  | 400 | F | 3A | LND | 1 | E | A | 0000 | LUZ2 | 1 | LND |
| F1150 |  | Scope of Facilities |  | 14d | 2008-03-03 A | 2008-03-20 A | F1000 SS, F3340 | 100% | F1150 | F1150 | 915 | AA | 0F |  |  | 200 | 200 | 001 | F | 3A | LND | 1 | E | A | 0000 | LUZ2 | 1 | LND |
| F1160 |  | Scope of Engineering Services |  | 14d | 2008-03-03 A | 2008-03-20 A | F3340, F1000 SS | 100% | F1160 | F1160 | 915 | AA | 0F |  |  | 200 | 200 | 001 | F | 3A | LND | 1 | E | A | 0000 | LUZ2 | 1 | LND |
| FCO002 |  | CO-02 Warehouse Concept |  | 18d | 2008-03-11 A | 2008-04-07 A | F2760 | 100% | FCO002 | FCO002 | 916 | AA | 0F |  |  | 200 | 200 | 001 | F | 3A | LND | 1 | E | A | 0000 | LUZ2 |  | LND |
| FCO003 |  | CO-03 Container Yard Concept |  | 18d | 2008-03-11 A | 2008-04-07 A | F2760 | 100% | FCO003 | FCO003 | 916 | AA | 0F |  |  | 200 | 200 | 001 | F | 3A | LND | 1 | E | A | 0000 | LUZ2 |  | LND |
| F1080 |  | OBCE Estimating Plan |  | 71d | 2008-03-17 A | 2008-06-27 A | F1000 SS, F1100 FF | 100% | F1080 | F1080 | L4 |  | 0F |  |  | 200 | 200 |  | F | 3A | LND | 1 | E | A | 0000 | LUZ2 | 1 | LND |
| F1140 |  | EPC Schedule |  | 81d | 2008-03-17 A | 2008-07-11 A | F1130 FS+12d, F1000 SS | 100% | F1140 | F1140 | 932 |  | 0F |  |  | 200 | 200 | 300 | F | 3A | LND | 1 | E | A | 0000 | LUZ2 | 1 | LND |
| FCO005 |  | CO-05 Redesign Reactor Overh.condenser |  | 88d | 2008-03-17 A | 2008-07-22 A | F2760 | 100% | FCO005 | FCO005 | 916 | AA | 0F |  |  | 200 | 200 | 001 | F | 3A | LND | 1 | E | A | 0000 | LUZ2 |  | LND |
| F1400 |  | OBCE Proced./ CBS Review Meeting with PMT |  | 2d | 2008-03-25 A | 2008-03-26 A |  | 100% | F1400 | F1400 | L4 |  | 0F |  |  | 200 | 200 |  | F | 3A | LND | 1 | E | A | 0000 | LUZ2 | 1 | LND |
| F2450 |  | OBCE Procedure/ CBS approved by PMT | milestone | 0d | 2008-04-05 A | 2008-04-05 A | F1400 FF+7d | 100% | F2450 | F2450 | L4 |  | 0F |  |  | 200 | 200 |  | F | 3A | LND | 1 | E | A | 0000 | LUZ2 | 1 | LND |
| FCO004 |  | CO-04 Warehouse Management System |  | 69d | 2008-04-09 A | 2008-07-16 A | F2760 | 100% | FCO004 | FCO004 | 916 | AA | 0F |  |  | 200 | 200 | 001 | F | 3A | LND | 1 | E | A | 0000 | LUZ2 |  | LND |
| FCO010 |  | CO-10 Warehouse Basic |  | 71d | 2008-04-18 A | 2008-07-29 A | F2760 | 100% | FCO010 | FCO010 | 916 | AA | 0F |  |  | 200 | 200 | 001 | F | 3A | LND | 1 | E | A | 0000 | LUZ2 |  | LND |
| FCO012 |  | CO-12 Russian requirements f. Reactor COEK |  | 79d | 2008-05-13 A | 2008-08-29 A | F2760 | 100% | FCO012 | FCO012 | 916 | AA | 0F |  |  | 200 | 200 | 001 | F | 3A | LND | 1 | E | A | 0000 | LUZ2 |  | LND |
| F2550 |  | Clarification Meeting Estimation Format with PMT |  | 2d | 2008-05-14 A | 2008-05-15 A | F2450 FS+25d | 100% | F2550 | F2550 | L4 |  | 0F |  |  | 200 | 200 |  | F | 3A | LND | 1 | E | A | 0000 | LUZ2 | 1 | LND |
| FCO009 |  | CO-09 Laboratory Planning |  | 48d | 2008-05-15 A | 2008-07-21 A | F2760 | 100% | FCO009 | FCO009 | 916 | AA | 0F |  |  | 200 | 200 | 001 | F | 3A | LND | 1 | E | A | 0000 | LUZ2 |  | LND |
| F1970 |  | Temporary Construction Power Requirements |  | 19d | 2008-06-02 A | 2008-06-26 A | F2760 | 100% | F1970 | F1970 | 934 |  | 0F |  |  | 200 | 200 | 500 | F | 3A | LND | 1 | E | A | 0000 | LUZ2 | 1 | LND |
| F2070 |  | Construction Management Plan |  | 20d | 2008-06-02 A | 2008-06-27 A | F1780 | 100% | F2070 | F2070 | 934 |  | 0F |  |  | 200 | 200 | 500 | F | 3A | LND | 1 | E | A | 0000 | LUZ2 | 1 | LND |
| F2780 |  | Estimated BOQ's (Civil,Steel, HVAC,Constr.Work) |  | 11d | 2008-06-02 A | 2008-06-16 A | F2760 | 100% | F2780 | F2780 | L4 |  | 0F |  |  | 200 | 200 |  | F | 3A | LND | 1 | E | A | 0000 | LUZ2 | 1 | LND |
| FCO007 |  | CO-07 Missing instrument Data Sheets |  | 40d | 2008-06-02 A | 2008-07-25 A | F2760 | 100% | FCO007 | FCO007 | 916 | AA | 0F |  |  | 200 | 200 | 001 | F | 3A | LND | 1 | E | A | 0000 | LUZ2 |  | LND |
| F2040 |  | Procurement Execution plan and Master Procuremen |  | 110d | 2008-06-03 A | 2008-11-05 A | F1140 FF, F1000 SS | 100% | F2040 | F2040 | 860 |  | 0F |  |  | 200 |  | 400 | F | 3A | LND | 1 | E | A | 0000 | LUZ2 | 1 | LND |
| F2050 |  | Contracts Execution plan & Contracts Development |  | 112d | 2008-06-03 A | 2008-11-07 A | F1000 SS, F1140 FF | 100% | F2050 | F2050 | 860 |  | 0F |  |  | 200 |  | 400 | F | 3A | LND | 1 | E | A | 0000 | LUZ2 | 1 | LND |
| F2770 |  | Deadline for Vendor quot., start evaluat. quotes | milestone | 0d | 2008-06-03 A | 2008-06-03 A | F2780 SF+1d | 100% | F2770 | F2770 | L4 |  | 0F |  |  | 200 | 200 |  | F | 3A | LND | 1 | E | A | 0000 | LUZ2 | 1 | LND |
| F1100 |  | Project Cost Estimate |  | 10d | 2008-06-16 A | 2008-06-27 A | F9050 FF, F9030 FF, F2780 FF, F1000 SS, F2440 FF, F4760 FF, F9040 FF, F2290 FF, F2310 FF, F9020 FF | 100% | F1100 | F1100 | L4 |  | 0F |  |  | 200 | 200 |  | F | 3A | LND | 1 | E | A | 0000 | LUZ2 | 1 | LND |
| F2800 |  | Internal closure date estimating aktivities | milestone | 0d | 2008-06-17 A | 2008-06-17 A | F2780 FF | 100% | F2800 | F2800 | L4 |  | 0F |  |  | 200 | 200 |  | F | 3A | LND | 1 | E | A | 0000 | LUZ2 | 1 | LND |
| F4770 |  | Clarification Session/ PMT appr. of EPCm OBCE |  | 7d | 2008-06-23 A | 2008-07-01 A | F2800 FS+1d | 100% | F4770 | F4770 | L4 |  | 0F |  |  | 200 | 200 |  | F | 3A | LND | 1 | E | A | 0000 | LUZ2 | C | LND |
| F9010 |  | Submit EPCm OBCE to PMT | milestone | 0d | 2008-07-02 A | 2008-07-02 A | F1100 FF | 100% | F9010 | F9010 | L4 |  | 0F |  |  | 200 | 200 |  | F | 3A | LND | 1 | E | A | 0000 | LUZ2 | E | PMT |

Notes:
- F1000: P3 Activity Log Info: 1.04
- F1010: P3 Activity Log Info: 2.01
- F1030: P3 Activity Log Info: 2.04
- F1090: P3 Activity Log Info: 2.11
- F1130: P3 Activity Log Info: 2.16
- F2740: P3 Activity Log Info: 18.03
- F1170: P3 Activity Log Info: 2.12
- F2030: P3 Activity Log Info: 18.02
- F2060: P3 Activity Log Info: 18.11
- F2750: P3 Activity Log Info: 18.04
- F1150: P3 Activity Log Info: 3.01
- F1160: P3 Activity Log Info: 3.02
- F1080: P3 Activity Log Info: 2.10
- F1140: P3 Activity Log Info: 2.17
- F1970: P3 Activity Log Info: 15.18
- F2070: P3 Activity Log Info: 19.01
- F2040: P3 Activity Log Info: 18.08 part of EPC Schedule
- F2050: P3 Activity Log Info: 18.09
- F1100: P3 Activity Log Info: 2.13

| ID | WBS | Activity | Type | Duration | Start | Finish | Predecessors | Complete | Resources | UDF_SAVE ACTID | UDF_SAVE ACT ID | Department | Constr. Area | Inquiry/Order No | PMT-Area | PMT-Schedule Org | PMT-Phase | PMT-Stage | PMT-Respons. | Zeigen/n. Zeigen | WBS Phase | WBS Discipline | WBS Type of Work | WBS Objects | IMS | UPT | PMT-Discipline | Pro Unit/DocCode | TB26 Ressource Budget |
| --- | --- | --- | --- | --- | --- | --- | --- | --- | --- | --- | --- | --- | --- | --- | --- | --- | --- | --- | --- | --- | --- | --- | --- | --- | --- | --- | --- | --- | --- |
|  | P | **P Process** |  |  | 2007-12-10 | 2011-05-25 |  |  |  |  |  |  |  |  |  |  |  |  |  |  |  |  |  |  |  |  |  |  |  |
| F1800 |  | Media List |  | 28d | 2007-12-10 A | 2008-01-23 A | F2760 | 100% |  | F1800 | F1800 | 924 | 0F | 999 | 200 | 200 | F | 3A | LND | 1 | E | P | 0000 | LUZ2 | 1 | LND |  |  |  |
| F1180 |  | Utility Spec./FEED & Product Spec. |  | 51d | 2007-12-19 A | 2008-03-05 A | F1000 SS+7d | 100% |  | F1180 | F1180 | 887 | 0F | 999 | 200 |  | F | 3A | LND | 1 | E | P | 0000 | LUZ2 | 1 | LND | 025 |  |  |
| F4800 |  | Process Design FEED |  | 159d | 2007-12-19 A | 2008-08-08 A | F1000 SS | 100% |  | F4800 | F4800 | 858 | 0F | 999 | 200 | 200 | F |  | LND |  | E | P | 0000 | LUZ2 | C | LND | 025 |  |  |
| F2390 |  | P&I Diagrams -Process ready for Review E1 |  | 71d | 2008-01-11 A | 2008-04-22 A | F2240, F1340 | 100% |  | F2390 | F2390 | 924 | 0F | 999 | 200 | 200 | F | 3A | LND | 1 | E | P | 0000 | LUZ2 | 1 | LND | 025 |  |  |
| F1340 |  | P & ID -upstream-Utilities internal issue |  | 37d | 2008-01-24 A | 2008-03-14 A | F2240 FS-2d, F2230 FS-2d | 100% |  | F1340 | F1340 | 924 | 0F | 999 | 200 | 200 | F | 3A | LND | 1 | E | P | 0000 | LUZ2 | 1 | LND | 025 |  |  |
| F1210 |  | Process Design Criteria |  | 27d | 2008-01-30 A | 2008-03-06 A | F2260 | 100% |  | F1210 | F1210 | 887 | 0F | 999 | 200 | 200 | F | 3A | LND | 1 | E | P | 0000 | LUZ2 | 1 | LND | 025 |  |  |
| F1230 |  | Process Flow Diagrams Process Plant 1st issue |  | 33d | 2008-01-30 A | 2008-03-14 A | F3890, F2260, F1000 SS | 100% |  | F1230 | F1230 | 887 | 0F | 999 | 200 | 200 | F | 3A | LND | 1 | E | P | 0000 | LUZ2 | 1 | LND | 025 |  |  |
| F1270 |  | Process Data Sheets -non Licensor Scope- |  | 94d | 2008-01-30 A | 2008-06-13 A | F2710, F1000 SS | 100% |  | F1270 | F1270 | 887 | 0F | 999 | 200 | 200 | F | 3A | LND | 1 | E | P | 0000 | LUZ2 | 1 | LND | 025 |  |  |
| F3880 |  | Process Description (part of PDP)-Licensor | milestone | 0d | 2008-01-30 A | 2008-01-30 A | F3510 FF | 100% |  | F3880 | F3880 | 887 | 0F | 999 | 200 | 200 | F | 3A | INE | 1 | E | P | 0000 | LUZ2 | PI | LND |  |  |  |
| F3890 |  | PFD-electronic release -Licensor | milestone | 0d | 2008-01-30 A | 2008-01-30 A | F3520 FF | 100% |  | F3890 | F3890 | 887 | 0F | 999 | 200 | 200 | F | 3A | INE | 1 | E | P | 0000 | LUZ2 | PI | LND |  |  |  |
| F4240 |  | Engineering/Design standards for PFD | milestone | 0d | 2008-01-30 A | 2008-01-30 A | F4230 FF | 100% |  | F4240 | F4240 | 887 | 0F | 999 | 200 | 200 | F | 3A | PMT | 1 | E | P | 0000 | LUZ2 |  | LND |  |  |  |
| F4830 |  | PDP Release | milestone | 0d | 2008-01-30 A | 2008-01-30 A | F2260 FF | 100% |  | F4830 | F4830 | 858 | 0F | 999 | 200 | 200 | F |  | LND |  | E | P | 0000 | LUZ2 | C | LND | 025 |  |  |
| F2690 |  | Process Verification |  | 104d | 2008-01-31 A | 2008-06-30 A | F2760 | 100% |  | F2690 | F2690 | 887 | 0F | 999 | 200 | 200 | F | 3A | LND | 1 | E | P | 0000 | LUZ2 | 1 | LND | 025 |  |  |
| F2370 |  | Process Flow Diagrams Utilities |  | 35d | 2008-02-05 A | 2008-03-26 A | F3520 FS+4d, F2360 FS+8d | 100% |  | F2370 | F2370 | 887 | 0F | 999 | 200 | 200 | F | 3A | LND | 1 | E | P | 0000 | LUZ2 | 1 | LND | 025 |  |  |
| F1330 |  | Specifications of Effluents |  | 6d | 2008-02-11 A | 2008-02-18 A | F1000 SS, F1320 FF | 100% |  | F1330 | F1330 | 887 | 0F | 999 | 200 | 200 | F | 3A | LND | 1 | E | P | 0000 | LUZ2 | 1 | LND |  |  |  |
| F3930 |  | P&I Diagrams -Utilities ready for Review E1 |  | 43d | 2008-02-20 A | 2008-04-22 A | F1340, F2390 FF | 100% |  | F3930 | F3930 | 924 | 0F | 999 | 200 | 200 | F | 3A | LND | 1 | E | P | 0000 | LUZ2 | PI | LND | 025 |  |  |
| F1220 |  | Process Description Process Plant 1st issue |  | 39d | 2008-02-22 A | 2008-04-18 A | F2370 SS+5d, F1000 SS, F2660 SS | 100% |  | F1220 | F1220 | 887 | 0F | 999 | 200 | 200 | F | 3A | LND | 1 | E | P | 0000 | LUZ2 | 1 | LND | 025 |  |  |
| F1320 |  | Raw Material, Catalyst & Chemicals Sum. |  | 7d | 2008-02-29 A | 2008-03-10 A | F1000 SS, F2230 FS+5d, F2260 FS+8d | 100% |  | F1320 | F1320 | 887 | 0F | 999 | 200 | 200 | F | 3A | LND | 1 | E | P | 0000 | LUZ2 | 1 | LND | 025 |  |  |
| F2660 |  | Process Studies |  | 83d | 2008-02-29 A | 2008-06-30 A | F2760 | 100% |  | F2660 | F2660 | 887 | 0F | 999 | 200 | 200 | F | 3A | LND | 1 | E | P | 0000 | LUZ2 | 1 | LND | 025 |  |  |
| F2720 |  | Block Flow Diagram |  | 17d | 2008-02-29 A | 2008-03-26 A | F2370 FF, F1000 SS+7d | 100% |  | F2720 | F2720 | 887 | 0F | 999 | 200 | 200 | F | 3A | LND | 1 | E | P | 0000 | LUZ2 | 1 | LND | 025 |  |  |
| F8760 |  | Review Vendor Drawings |  | 83d | 2008-02-29 A | 2008-06-30 A | E3ALL140 SS | 100% |  | F8760 | F8760 | 887 | 0F | 999 | 200 | 200 | F | 3A | LND | 1 | E | P | 0000 | LUZ2 | E | PMT | 025 |  |  |
| F1190 |  | Interface/Battery Limit List 1st Issue |  | 13d | 2008-03-05 A | 2008-03-25 A | F1340 FF+5d, F1000 SS | 100% |  | F1190 | F1190 | 924 | 0F | 999 | 200 | 200 | F | 3A | LND | 1 | E | P | 0000 | LUZ2 | 1 | LND | 025 |  |  |
| F4180 |  | Engineering/Design standards for P&ID | milestone | 0d | 2008-03-14 A | 2008-03-14 A | F4170 FF | 100% |  | F4180 | F4180 | 924 | 0F | 999 | 200 | 200 | F | 3A | LND | 1 | E | P | 0000 | LUZ2 |  | LND | 025 |  |  |
| F4810 |  | P & ID Utilities | milestone | 0d | 2008-03-15 A | 2008-03-15 A | F4830, F1340 FF | 100% |  | F4810 | F4810 | 858 | 0F | 999 | 200 | 200 | F |  | LND |  | E | P | 0000 | LUZ2 | C | LND | 025 |  |  |
| F1710 |  | Instrument DS for TAP (MSB) |  | 36d | 2008-03-17 A | 2008-05-08 A | F1340 FF+5d | 100% |  | F1710 | F1710 | 924 | 0F | 999 | 200 | 200 | F | 3A | LND | 1 | E | P | 0000 | LUZ2 | 1 | LND | 025 |  |  |
| F1310 |  | Utility Summary |  | 69d | 2008-03-20 A | 2008-06-30 A | F1000 SS | 100% |  | F1310 | F1310 | 887 | 0F | 999 | 200 | 200 | F | 3A | LND | 1 | E | P | 0000 | LUZ2 | 1 | LND | 025 |  |  |
| F1390 |  | P&ID process/utilities final issue |  | 42d | 2008-03-20 A | 2008-05-22 A | F8990 | 100% |  | F1390 | F1390 | 924 | 0F | 999 | 200 | 200 | F | 3A | LND | 1 | E | P | 0000 | LUZ2 | 1 | LND | 025 |  |  |
| F1760 |  | Piping Line Lists prel. (E1) |  | 33d | 2008-03-20 A | 2008-05-08 A | F3930, F2390 SS | 100% |  | F1760 | F1760 | 924 | 0F | 999 | 200 | 200 | F | 3A | LND | 1 | E | P | 0000 | LUZ2 | 1 | LND | 025 |  |  |
| F2330 |  | Process Flow Diagrams Storage 1st issue |  | 46d | 2008-03-26 A | 2008-05-30 A | F3700 | 100% |  | F2330 | F2330 | 887 | 0F | 999 | 200 | 200 | F | 3A | LND | 1 | E | P | EP40 | LUZ2 | 1 | LND | 025 |  |  |
| F1770 |  | Interface/Battery Limit List 2nd issue (E1) |  | 16d | 2008-04-16 A | 2008-05-08 A | F3930 FF+5d, F2390 FF+5d | 100% |  | F1770 | F1770 | 924 | 0F | 999 | 200 | 200 | F | 3A | LND | 1 | E | P | 0000 | LUZ2 | 1 | LND | 025 |  |  |
| F8620 |  | Valve list final (E1) MTO from P&ID |  | 10d | 2008-04-16 A | 2008-04-29 A | F3930 FF+5d | 100% |  | F8620 | F8620 | 924 | 0F | 999 | 200 | 200 | F | 3A | LND | 1 | E | P | 0000 | LUZ2 | E | PMT | 025 |  |  |
| F8750 |  | Final issue of updated documents |  | 49d | 2008-04-21 A | 2008-06-30 A | F2690 FF | 100% |  | F8750 | F8750 | 887 | 0F | 999 | 200 | 200 | F | 3A | LND | 1 | E | P | 0000 | LUZ2 | E | PMT |  |  |  |
| F2380 |  | Process Description Storage 1st issue |  | 32d | 2008-04-22 A | 2008-06-06 A | F2330 FF | 100% |  | F2380 | F2380 | 887 | 0F | 999 | 200 | 200 | F | 3A | LND | 1 | E | P | 0000 | LUZ2 | 1 | LND | 025 |  |  |
| F1280 |  | Process Interlock Descriptions |  | 47d | 2008-04-23 A | 2008-06-30 A | F3930 | 100% |  | F1280 | F1280 | 924 | 0F | 999 | 200 | 200 | F | 3A | LND | 1 | E | P | 0000 | LUZ2 | 1 | LND | 025 |  |  |
| F1730 |  | updated Instrument DS for TAP (MSB) |  | 11d | 2008-04-23 A | 2008-05-08 A | F3930 FF+5d, F2390 FF+5d | 100% |  | F1730 | F1730 | 924 | 0F | 999 | 200 | 200 | F | 3A | LND | 1 | E | P | 0000 | LUZ2 | 1 | LND | 025 |  |  |
| F2960 |  | P&I Diagramms ready for Review E1 | milestone | 0d | 2008-04-23 A | 2008-04-23 A | F2390 FF, F3930 FF | 100% |  | F2960 | F2960 | 924 | 0F | 999 | 200 | 200 | F |  |  |  | E | P | 0000 | LUZ2 | P | LND | 025 | 91 |  |
| F3940 |  | P & IDs ready for Review | milestone | 0d | 2008-04-23 A | 2008-04-23 A | F2390 FF, F3930 FF | 100% |  | F3940 | F3940 | 924 | 0F | 999 | 200 | 200 | F | 3A | LND | 1 | E | P | 0000 | LUZ2 | PI | LND | 025 |  |  |
| F1290 |  | Heat and Material Balances |  | 41d | 2008-04-30 A | 2008-06-27 A | F1000 SS+13d | 100% |  | F1290 | F1290 | 887 | 0F | 999 | 200 | 200 | F | 3A | LND | 1 | E | P | 0000 | LUZ2 | 1 | LND | 025 |  |  |
| F8610 |  | P&ID Review Process/Utilities based on E1 |  | 7d | 2008-05-05 A | 2008-05-14 A | F3940 FS+7d | 100% |  | F8610 | F8610 | 924 | 0F | 999 | 200 | 200 | F | 3A | LND | 1 | E | P | 0000 | LUZ2 | E | PMT | 025 |  |  |
| F8990 |  | Incorporate comments from P&ID Review |  | 14d | 2008-05-05 A | 2008-05-23 A | F8610 FF | 100% |  | F8990 | F8990 | 924 | 0F | 999 | 200 | 200 | F | 3A | LND | 1 | E | P | 0000 | LUZ2 | E | PMT | 025 |  |  |
| F4820 |  | P & ID Status ready for HAZOP (Feed Phase) | milestone | 0d | 2008-05-24 A | 2008-05-24 A | F9000 FF, EP40000 FF, F4810 | 100% |  | F4820 | F4820 | 858 | 0F | 999 | 200 | 200 | F |  | LND |  | E | P | 0000 | LUZ2 | C | LND | 025 |  |  |
| F9000 |  | P&ID Issue ready for HAZOP (Feed Phase) | milestone | 0d | 2008-05-24 A | 2008-05-24 A | F8990 FF | 100% |  | F9000 | F9000 | 924 | 0F | 999 | 200 | 200 | F | 3A | LND | 1 | E | P | 0000 | LUZ2 | E | PMT | 025 |  |  |
| A1CF2052 |  | P&ID Status E2 Downstream Part |  | 24d | 2008-09-08 A | 2008-10-10 A | A1CS0352 FF+15d | 100% |  | A1CF2052 | A1CF2052 | 924 | 0F | 999 | 200 | 200 | AD |  | LND |  | E | P | EF10 | LUZ2 | 1 | LND | 025 |  |  |
| A1CF2062 |  | Revised P&ID Status E2 |  | 57d | 2008-09-08 A | 2008-11-28 A | AD1250 FF, A1010025 | 100% |  | A1CF2062 | A1CF2062 | 924 | 0F | 999 | 200 | 200 | AD |  | LND |  | E | P | EF10 | LUZ2 | 1 | LND | 025 |  |  |
| A1CF0230 |  | Pipeline List Status E2 f. Cost Estimate |  | 15d | 2008-12-01 A | 2008-12-19 A | A1CF2062 | 100% |  | A1CF0230 | A1CF0230 | 924 | 0F | 999 | 200 | 200 | AD |  | LND |  | E | P | EF15 | LUZ2 | ML | LND | 025 |  |  |
| EP000165 |  | Participation 60% DSRV -downstream- | level of effort | 7d | 2009-10-19 A | 2009-10-27 A | F4035 SS, F4035 FF | 100% |  | EP000165 | EP000165 | 858 | 0F | 999 | 200 | 200 | F |  | LND |  | E | P | 0000 | LUZ2 | 1 | LND | 025 | 999 |  |
| EP000160 |  | Participation 60% DSRV -upstream- 11/12/13/51/55-56 | level of effort | 12d | 2009-11-02 A | 2009-11-17 A | EP000165, F4030 SS, F4030 FF | 100% |  | EP000160 | EP000160 | 858 | 0F | 999 | 200 | 200 | F |  | LND |  | E | P | 0000 | LUZ2 | 1 | LND | 025 | 999 |  |
| A1CF0250 |  | Pipeline List Status update all Systems (w/o 10/14/53) |  | 386d | 2009-11-16 A | 2011-05-25 A | A1CF0230, EF00100 FF+4d, IMS-E-000030 FF | 100% | CB [720 h] | A1CF0250 | A1CF0250 | 924 | 0F | 999 | 200 | 200 | AD |  | LND |  | E | P | EF15 | LUZ2 | 1 | LND | 025 |  | 720,00 |
| EF1000 |  | General Task & Coordiantions DE Phase (CB) |  | 372d | 2009-12-01 A | 2011-05-19 A | EF00100 FF, DE1000 | 100% | CB [19200 h] | EF1000 | EF1000 | 924 | 0F | 999 | 200 | 200 | F | 3A | LND | 1 | E | P | 0000 | LUZ2 | 1 | LND | 025 |  | 19200,00 |
| EP1000 |  | General Task & Coordiantions DE Phase (CP) |  | 231d | 2009-12-01 A | 2010-10-29 A | DE1000 | 100% | CP [880 h] | EP1000 | EP1000 | 887 | 0F | 999 | 200 | 200 | F | 3A | LND | 1 | E | P | 0000 | LUZ2 | 1 | LND | 025 |  | 880,00 |
| EF000100 |  | First Level Support |  | 79d | 2009-12-07 A | 2010-03-31 A | DE1000 FS+30d | 100% | CB [360 h] | EF000100 | EF000100 | 924 | 0F | 999 | 200 | 200 | F | 3A | LND | 1 | E | P | 0000 | LUZ2 | 1 | LND | 025 |  | 360,00 |
| EP000200 |  | Participation 60% DSRV -upstream- 15/16/17/52/54 | level of effort | 15d | 2010-03-01 A | 2010-03-19 A | EP000160, F4040 FF, F4040 SS | 100% |  | EP000200 | EP000200 | 858 | 0F | 999 | 200 | 200 | F |  | LND |  | E | P | 0000 | LUZ2 | 1 | LND | 025 |  |  |
| EP000190 |  | Participation 90% DSRV -downstream- | level of effort | 10d | 2010-04-26 A | 2010-05-07 A | F9250 SS, EP000200, F9250 FF | 100% |  | EP000190 | EP000190 | 858 | 0F | 999 | 200 | 200 | F |  | LND |  | E | P | 0000 | LUZ2 | 1 | LND | 025 |  |  |
| EP000195 |  | Participation 90% DSRV -upstream- 11/12/13/51-56 | level of effort | 15d | 2010-06-21 A | 2010-07-09 A | EP000190, F4460 SS, F4460 FF | 100% |  | EP000195 | EP000195 | 858 | 0F | 999 | 200 | 200 | F |  | LND |  | E | P | 0000 | LUZ2 | 1 | LND | 025 |  |  |
| A1CF0261 |  | Pipeline List Status H - CA11 |  | 25d | 2010-11-25 A | 2010-12-30 A | IMS-E-000040 FF+10d | 100% |  | A1CF0261 | A1CF0261 | 924 | 0F | 999 | 200 | 200 | AD |  | LND |  | E | P | EF15 | LUZ2 | 1 | LND | 025 |  |  |
| A1CF0262 |  | Pipeline List Status H - CA12 |  | 25d | 2010-11-29 A | 2011-01-04 A | IMS-E-000041 FF+10d | 100% |  | A1CF0262 | A1CF0262 | 924 | 0F | 999 | 200 | 200 | AD |  | LND |  | E | P | EF15 | LUZ2 | 1 | LND | 025 |  |  |
| A1CF0263 |  | Pipeline List Status H - CA13 |  | 24.5d | 2010-12-06 A | 2011-01-11 A | IMS-E-000042 FF+10d | 100% |  | A1CF0263 | A1CF0263 | 924 | 0F | 999 | 200 | 200 | AD |  | LND |  | E | P | EF15 | LUZ2 | 1 | LND | 025 |  |  |
| A1CF0264 |  | Pipeline List Status H - CA51 |  | 24.5d | 2010-12-06 A | 2011-01-11 A | IMS-E-000043 FF+10d | 100% |  | A1CF0264 | A1CF0264 | 924 | 0F | 999 | 200 | 200 | AD |  | LND |  | E | P | EF15 | LUZ2 | 1 | LND | 025 |  |  |
| A1CF0271 |  | Pipeline List Status H - CA52/54/55/56 |  | 24.5d | 2010-12-06 A | 2011-01-11 A | IMS-E-000046 FF+10d | 100% |  | A1CF0271 | A1CF0271 | 924 | 0F | 999 | 200 | 200 | AD |  | LND |  | E | P | EF15 | LUZ2 | 1 | LND | 025 |  |  |
| A1CF0260 |  | Pipeline List Status H - CA31 |  | 19.16d | 2010-12-06 A | 2011-01-04 A | IMS-E-000035 FF+10d | 100% |  | A1CF0260 | A1CF0260 | 924 | 0F | 999 | 200 | 200 | AD |  | LND |  | E | P | EF15 | LUZ2 | 1 | LND | 025 |  |  |
| A1CF0270 |  | Pipeline List Status H - CA17 |  | 25d | 2011-03-28 A | 2011-04-29 A | IMS-E-000045 FF+4d, EF00110 FF+5d | 100% |  | A1CF0270 | A1CF0270 | 924 | 0F | 999 | 200 | 200 | AD |  | LND |  | E | P | EF15 | LUZ2 | 1 | LND | 025 |  |  |
| A1CF0275 |  | Pipeline List Status H - CA10/14/53 |  | 39d | 2011-03-28 A | 2011-05-19 A | A1CF0262 FF, A1CF0270 FF, A1CF0261 FF, IMS-E-000050 FF, A1CF0263 FF, A1CF0271 FF, A1CF0260 FF, A1CF0264 FF | 100% |  | A1CF0275 | A1CF0275 | 924 | 0F | 999 | 200 | 200 | AD |  | LND |  | E | P | EF15 | LUZ2 | 1 | LND | 025 |  |  |

Notes:
- F1180: P3 Activity Log Info: 3.04
- F2390: P3 Activity Log Info: 4.15a
- F1210: P3 Activity Log Info: 4.01
- F1230: P3 Activity Log Info: 4.03a
- F1270: P3 Activity Log Info: 4.07
- F2370: P3 Activity Log Info: 4.03c
- F1330: P3 Activity Log Info: 4.14
- F3930: P3 Activity Log Info: 4.15b
- F1220: P3 Activity Log Info: 4.02a
- F1320: P3 Activity Log Info: 4.13
- F2720: P3 Activity Log Info: 4.09
- F1190: P3 Activity Log Info: 3.05
- F1310: P3 Activity Log Info: 4.12
- F1760: P3 Activity Log Info: 14.03a
- F2330: P3 Activity Log Info: 4.03b
- F1770: P3 Activity Log Info: 14.05
- F2380: P3 Activity Log Info: 4.02b
- F1280: P3 Activity Log Info: 4.08
- F1290: P3 Activity Log Info: 4.10
- A1CF2052: P3 Activity Log Info: Status F: Detail Concept / AFD = approved for Detail Engineering
- A1CF2062: P3 Activity Log Info: Status F: Detail Concept / AFD = approved for Detail Engineering
- A1CF0230: P3 Activity Log Info: Status F: Detail Concept / AFD = approved for Detail Engineering
- A1CF0250: P3 Activity Log Info: Status F: Detail Concept / AFD = approved for Detail Engineering
- EF1000: P3 Activity Log Info: 14.03b
- EP1000: P3 Activity Log Info: 14.03b
- EF000100: P3 Activity Log Info: 14.03b
- A1CF0261: P3 Activity Log Info: Status F: Detail Concept / AFD = approved for Detail Engineering
- A1CF0262: P3 Activity Log Info: Status F: Detail Concept / AFD = approved for Detail Engineering
- A1CF0263: P3 Activity Log Info: Status F: Detail Concept / AFD = approved for Detail Engineering
- A1CF0264: P3 Activity Log Info: Status F: Detail Concept / AFD = approved for Detail Engineering
- A1CF0271: P3 Activity Log Info: Status F: Detail Concept / AFD = approved for Detail Engineering
- A1CF0260: P3 Activity Log Info: Status F: Detail Concept / AFD = approved for Detail Engineering
- A1CF0270: P3 Activity Log Info: Status F: Detail Concept / AFD = approved for Detail Engineering
- A1CF0275: P3 Activity Log Info: Status F: Detail Concept / AFD = approved for Detail Engineering

| ID | WBS | Activity | Type | Duration | Start | Finish | Predecessors | Complete | UDF_SAVE ACTID | UDF_SAVE ACT ID | Department | Constr. Area | PMT-Area | PMT-Schedule Org | PMT-Discipline | PMT-Phase | PMT-Stage | PMT-Respons. | Zeigen/n. Zeigen | WBS Phase | WBS Discipline | WBS Type of Work | WBS Objects | IMS | UPT | Pro Unit/DocCode |
| --- | --- | --- | --- | --- | --- | --- | --- | --- | --- | --- | --- | --- | --- | --- | --- | --- | --- | --- | --- | --- | --- | --- | --- | --- | --- | --- |
|  | L | **L Plant Design** |  |  | 2008-02-01 | 2009-01-16 |  |  |  |  |  |  |  |  |  |  |  |  |  |  |  |  |  |  |  |  |
| F1810 |  | Plot Plan preliminary |  | 26d | 2008-02-01 A | 2008-03-07 A | F3600 FF-5d | 100% | F1810 | F1810 | 876 | 0F | 200 | 200 | 050 | F | 3A | LND | 1 | E | L | 0000 | LUZ2 | 1 | LND |  |
| F1780 |  | Plot Plans 1st issue |  | 41d | 2008-03-10 A | 2008-05-08 A | F1810, F2260 FS+5d, F1000 SS | 100% | F1780 | F1780 | 876 | 0F | 200 | 200 | 050 | F | 3A | LND | 1 | E | L | 0000 | LUZ2 | 1 | LND |  |
| F3400 |  | Plotplan freeze PP Plant | milestone | 0d | 2008-05-09 A | 2008-05-09 A | F1780 FF | 100% | F3400 | F3400 | 876 | 0F | 200 | 200 |  |  |  | LND |  | E | L | 0000 | LUZ2 | PI | LND | 91 |
| F1200 |  | Design/Model reviews schedule |  | 21d | 2008-06-02 A | 2008-06-30 A | F1000 SS, F1780 FS-4d | 100% | F1200 | F1200 | 876 | 0F | 200 | 200 | 050 | F | 3A | LND | 1 | E | L | 0000 | LUZ2 | 1 | LND |  |
| F4140 |  | Overall Plotplan PP Plant confirmed by PMT | milestone | 0d | 2009-01-16 A | 2009-01-16 A | F4130 FF, F3810 | 100% | F4140 | F4140 | 876 | 0F | 200 | 200 | 050 | F | 3A | PMT | 1 | E | L | 0000 | LUZ2 |  | LND |  |
|  | C | **C Civil** |  |  | 2008-02-01 | 2008-10-01 |  |  |  |  |  |  |  |  |  |  |  |  |  |  |  |  |  |  |  |  |
| F4280 |  | Clarification Geotechnical Investig. PP Plant | milestone | 0d | 2008-02-01 A | 2008-02-01 A | F4270 FF | 100% | F4280 | F4280 | 87A | 0F | 200 | 200 |  | F | 3A | PMT | 1 | E | C | EC00 | LUZ2 |  | LND |  |
| F8860 |  | Survey of existing conditions (as built) |  | 72d | 2008-02-01 A | 2008-05-16 A | F8820 | 100% | F8860 | F8860 | 87A | 0F | 200 | 200 | 010 | F | 3A | LND | 1 | E | C | EC00 | LUZ2 | E | PMT |  |
| F1470 |  | Foundation Design Criteria |  | 71d | 2008-02-04 A | 2008-05-16 A | F4260 | 100% | F1470 | F1470 | 87A | 0F | 200 | 200 | 010 | F | 3A | LND | 1 | E | C | EC00 | LUZ2 | 1 | LND |  |
| F8820 |  | Verification of order&contract/bid Calculation |  | 20d | 2008-02-04 A | 2008-02-29 A | F2760 | 100% | F8820 | F8820 | 87A | 0F | 200 | 200 |  | F | 3A | LND | 1 | E | C | EC00 | LUZ2 | E | PMT |  |
| F8830 |  | Order specification for Civil FEED Engineering |  | 71d | 2008-02-04 A | 2008-05-16 A | F8820 | 100% | F8830 | F8830 | 87A | 0F | 200 | 200 | 010 | F | 3A | LND | 1 | E | C | EC00 | LUZ2 | E | PMT |  |
| F8840 |  | Subcontracting Engineering |  | 71d | 2008-02-18 A | 2008-05-30 A | F8830 | 100% | F8840 | F8840 | 87A | 0F | 200 | 200 | 010 | F | 3A | LND | 1 | E | C | EC00 | LUZ2 | E | PMT |  |
| F1440 |  | Civil Design basis |  | 49d | 2008-03-03 A | 2008-05-14 A | F4260, F3600 FF | 100% | F1440 | F1440 | 87A | 0F | 200 | 200 | 010 | F | 3A | LND | 1 | E | C | EC00 | LUZ2 | 1 | LND |  |
| F1590 |  | Architectural Design Basis |  | 49d | 2008-03-03 A | 2008-05-14 A | F1000 SS+16d, F1440 SS, F4260, F3600 FF | 100% | F1590 | F1590 | 87A | 0F | 200 | 200 | 010 | F | 3A | LND | 1 | E | C | EC00 | LUZ2 | 1 | LND |  |
| F8850 |  | CAD/ Modell support/documenthandling/-list |  | 126d | 2008-03-03 A | 2008-08-29 A | F8820 | 100% | F8850 | F8850 | 87A | 0F | 200 | 200 | 010 | F | 3A | LND | 1 | E | C | EC00 | LUZ2 | E | PMT |  |
| F1460 |  | Site Geotechnical Specification |  | 40d | 2008-03-27 A | 2008-05-23 A | F1000 SS+16d, F1780 FF+10d | 100% | F1460 | F1460 | 87A | 0F | 200 | 200 | 010 | F | 3A | LND | 1 | E | C | EC00 | LUZ2 | 1 | LND |  |
| F1550 |  | Foundation Location Plans |  | 90d | 2008-04-23 A | 2008-08-28 A | F8950 SS+23d, F8960 SS+5d, F1780 | 100% | F1550 | F1550 | 87A | 0F | 200 | 200 | 010 | F | 3A | LND | 1 | E | C | EC00 | LUZ2 | 1 | LND |  |
| F1510 |  | Grading and Drainage design / Drawings |  | 89d | 2008-04-25 A | 2008-08-29 A | F1780, F1000 SS+16d | 100% | F1510 | F1510 | 87A | 0F | 200 | 200 | 010 | F | 3A | LND | 1 | E | C | EC00 | LUZ2 | 1 | LND |  |
| F8920 |  | Preparation BOQ acc. OBCE Proc. |  | 34d | 2008-04-28 A | 2008-06-16 A | F1100 SF+1d | 100% | F8920 | F8920 | 87A | 0F | 200 | 200 | 010 | F | 3A | LND | 1 | E | C | EC00 | LUZ2 | E | PMT |  |
| F1500 |  | Roads and Paving Plan / Drawings |  | 85d | 2008-05-02 A | 2008-08-29 A | F1780 FS-8d | 100% | F1500 | F1500 | 87A | 0F | 200 | 200 | 010 | F | 3A | LND | 1 | E | C | EC00 | LUZ2 | 1 | LND |  |
| F8880 |  | Pipe rack/Supports layout (supp. for TKB-S) |  | 63d | 2008-05-05 A | 2008-07-31 A | F1560 FF | 100% | F8880 | F8880 | 87A | 0F | 200 | 200 | 010 | F | 3A | LND | 1 | E | C | EC00 | LUZ2 | E | PMT |  |
| F1580 |  | Building Definition, Layout and Design Drwgs |  | 65d | 2008-06-02 A | 2008-08-29 A | F1950 FF, F1780 | 100% | F1580 | F1580 | 87A | 0F | 200 | 200 | 010 | F | 3A | LND | 1 | E | C | EC00 | LUZ2 | 1 | LND |  |
| F1600 |  | Building Structural Design Sketches |  | 62d | 2008-06-02 A | 2008-08-26 A | F1580 SS, F1810 FS+1d | 100% | F1600 | F1600 | 87A | 0F | 200 | 200 | 010 | F | 3A | LND | 1 | E | C | EC00 | LUZ2 | 1 | LND |  |
| F8870 |  | Underground layout (supp. for plant design dep.) |  | 24d | 2008-06-27 A | 2008-07-30 A | F4470 FF | 100% | F8870 | F8870 | 87A | 0F | 200 | 200 |  | F | 3A | LND | 1 | E | C | EC00 | LUZ2 | E | PMT |  |
| F4310 |  | Standardization BoQ for Civil | milestone | 0d | 2008-06-28 A | 2008-06-28 A | F4300 FF, F4690 | 100% | F4310 | F4310 | 87A | 0F | 200 | 200 | 010 | F | 3A | PMT | 1 | E | C | EC00 | LUZ2 |  | LND |  |
| F4260 |  | Standardization Civil eng./design standards | milestone | 0d | 2008-10-01 A | 2008-10-01 A | F4250 FF | 100% | F4260 | F4260 | 87A | 0F | 200 | 200 | 010 | F | 3A | PMT | 1 | E | C | EC00 | LUZ2 |  | LND |  |

Notes:
- F1780: P3 Activity Log Info: 14.07a
- F1200: P3 Activity Log Info: 3.06
- F4140: P3 Activity Log Info: commited delivery date 31DEC07
- F1470: P3 Activity Log Info: 6.04
- F1440: P3 Activity Log Info: 6.01
- F1590: P3 Activity Log Info: 8.02
- F1460: P3 Activity Log Info: 6.03
- F1550: P3 Activity Log Info: 7.04
- F1510: P3 Activity Log Info: 6.08
- F1500: P3 Activity Log Info: 6.07
- F1580: P3 Activity Log Info: 8.01
- F1600: P3 Activity Log Info: 8.03

| ID | WBS | Activity | Type | Duration | Start | Finish | Predecessors | Complete | Resources | UDF_SAVE ACTID | UDF_SAVE ACT ID | Department | Constr. Area | PMT-Area | PMT-Schedule Org | PMT-Discipline | PMT-Phase | PMT-Stage | PMT-Respons. | Zeigen/n. Zeigen | WBS Phase | WBS Discipline | WBS Type of Work | WBS Objects | IMS | UPT | Pro Unit/DocCode | Type of Work | Inquiry/Order No | PMT-Doc. Type | TB26 Ressource Budget |
| --- | --- | --- | --- | --- | --- | --- | --- | --- | --- | --- | --- | --- | --- | --- | --- | --- | --- | --- | --- | --- | --- | --- | --- | --- | --- | --- | --- | --- | --- | --- | --- |
|  | N | **N Structural Steel** |  |  | 2008-01-28 | 2008-08-29 |  |  |  |  |  |  |  |  |  |  |  |  |  |  |  |  |  |  |  |  |  |  |  |  |  |
| F1530 |  | Structural Design Basis (incl. Typicals) |  | 100d | 2008-01-28 A | 2008-06-19 A | F1000 SS | 100% |  | F1530 | F1530 | 87B | 0F | 200 | 200 | 015 | F | 3A | LND | 1 | E | N | 0000 | LUZ2 | 1 | LND |  |  |  |  |  |
| F8950 |  | Structural Steel Concepts |  | 95d | 2008-03-03 A | 2008-07-17 A | F1530 FF | 100% |  | F8950 | F8950 | 87B | 0F | 200 | 200 | 015 | F | 3A | LND | 1 | E | N | EN15 | LUZ2 | E | PMT |  |  |  |  |  |
| F8960 |  | Structural Steel 3D Modell Design |  | 66d | 2008-04-29 A | 2008-07-31 A | F1780 FS-5d | 100% |  | F8960 | F8960 | 87B | 0F | 200 | 200 | 015 | F | 3A | LND | 1 | E | N | 0000 | LUZ2 | E | PMT |  |  |  |  |  |
| F2440 |  | Struc Steel - Preparation BOQ acc. OBCE Proc. |  | 15d | 2008-05-27 A | 2008-06-16 A | F2760 | 100% |  | F2440 | F2440 | 87B | 0F | 200 | 200 | 015 | F | 3A | LND | 1 | E | N | 0000 | LUZ2 | 1 | LND |  |  |  |  |  |
| F1570 |  | Revised RFQs incl. structural steel description |  | 50d | 2008-06-23 A | 2008-08-29 A | F1000 SS, F1560 FF | 100% |  | F1570 | F1570 | 87B | 0F | 200 | 200 | 015 | F | 3A | LND | 1 | E | N | 0000 | LUZ2 | 1 | LND |  |  |  |  |  |
| F1560 |  | Structural Steel Design Drawings |  | 39d | 2008-07-07 A | 2008-08-28 A | F8960 FF+22d, F1780, F8940 SF+30d, F2540 FF+30d, F8930 SF+20d | 100% |  | F1560 | F1560 | 87B | 0F | 200 | 200 | 015 | F | 3A | LND | 1 | E | N | 0000 | LUZ2 | 1 | LND |  |  |  |  |  |
|  | H | **H HVAC** |  |  | 2008-01-21 | 2008-11-10 |  |  |  |  |  |  |  |  |  |  |  |  |  |  |  |  |  |  |  |  |  |  |  |  |  |
| F1610 |  | HVAC Design Basis |  | 111d | 2008-01-21 A | 2008-06-27 A | F1780 FF+20d | 100% |  | F1610 | F1610 | 87C | 0F | 200 | 200 | 035 | F | 3A | LND | 1 | E | H | 0000 | LUZ2 | 1 | LND |  |  |  |  |  |
| F1630 |  | HVAC Flow Diagrams |  | 133d | 2008-02-29 A | 2008-09-08 A | F1610 SS+5d, F1000 SS, F1810 | 100% |  | F1630 | F1630 | 87C | 0F | 200 | 200 | 035 | F | 3A | LND | 1 | E | H | 0000 | LUZ2 | 1 | LND |  |  |  |  |  |
| F1620 |  | HVAC General Notes/Systemdescription |  | 127d | 2008-03-10 A | 2008-09-08 A | F1810, F1610 SS+5d, F1000 SS | 100% |  | F1620 | F1620 | 87C | 0F | 200 | 200 | 035 | F | 3A | LND | 1 | E | H | 0000 | LUZ2 | 1 | LND |  |  |  |  |  |
| F1740 |  | HVAC - Input for Civil/Structural Steel |  | 129d | 2008-05-09 A | 2008-11-10 A | F1780 | 100% |  | F1740 | F1740 | 87C | 0F | 200 | 200 | 035 | F | 3A | LND | 1 | E | H | 0000 | LUZ2 | 1 | LND |  |  |  |  |  |
| F1700 |  | HVAC Equipment List |  | 65d | 2008-05-19 A | 2008-08-15 A | F1780, F1620 FF | 100% |  | F1700 | F1700 | 87C | 0F | 200 | 200 | 035 | F | 3A | LND | 1 | E | H | 0000 | LUZ2 | 1 | LND |  |  |  |  |  |
| F2290 |  | HVAC - Preparation BOQ acc. OBCE Proc. |  | 15d | 2008-05-27 A | 2008-06-16 A |  | 100% |  | F2290 | F2290 | 87C | 0F | 200 | 200 | 035 | F | 3A | LND | 1 | E | H | 0000 | LUZ2 | 1 | LND |  |  |  |  |  |
| F1690 |  | Plumbing Design Basis (HVAC) |  | 61d | 2008-06-16 A | 2008-09-08 A | F1780 FS+25d | 100% |  | F1690 | F1690 | 87C | 0F | 200 | 200 | 035 | F | 3A | LND | 1 | E | H | 0000 | LUZ2 | 1 | LND |  |  |  |  |  |
| F4120 |  | Standardization HVAC&Plumbing BoQ | milestone | 0d | 2008-07-19 A | 2008-07-19 A | F2290 | 100% |  | F4120 | F4120 | 87C | 0F | 200 | 200 | 035 | F | 3A | PMT | 1 | E | H | 0000 | LUZ2 |  | LND |  |  |  |  |  |
|  | U | **U Package Units** |  |  | 2008-01-14 | 2010-09-24 |  |  |  |  |  |  |  |  |  |  |  |  |  |  |  |  |  |  |  |  |  |  |  |  |  |
| F1720 |  | Design Study Conveying/Produkt Handling/Layout |  | 54d | 2008-01-14 A | 2008-03-31 A | F2760 | 100% |  | F1720 | F1720 | 869 | 0F | 200 | 200 | 055 | F | 3A | LND | 1 | E | U | 0000 | LUZ2 | 1 | LND |  |  |  |  |  |
| F3430 |  | Conveying/Warehouse/Logistics-Concept Definition |  | 50d | 2008-01-21 A | 2008-04-01 A | F3420 SS | 100% |  | F3430 | F3430 | 869 | 0F | 200 | 200 |  |  |  |  |  | E | U | 0000 | LUZ2 | PI | LND | 90 |  |  |  |  |
| F3680 |  | Phase 1a- Concept Definition |  | 29d | 2008-01-21 A | 2008-02-28 A | F3430 FF | 100% |  | F3680 | F3680 | N | 0F | 200 | 200 |  | F | 3A | LND | 1 | E | U | 0000 | LUZ2 | PI | LND |  |  |  |  |  |
| F4750 |  | Phase 1 Product Handling | level of effort | 54d | 2008-01-21 A | 2008-04-07 A | F3680 SS | 100% |  | F4750 | F4750 | N | 0F | 200 | 200 | 025 | F |  |  |  | E | U | 0000 | LUZ2 | C | LND |  |  |  |  |  |
| F10400 |  | PU10 Convey. Syst. - Concept Phase |  | 48d | 2008-01-22 A | 2008-03-31 A | F1660 SS+15d, F1540 SS | 100% |  | F10400 | F10400 | 869 | 0F | 200 | 200 | 055 | E | 3A | LND | C2 | E | U | EU13 | LUZ2 | 1 | LND | DC | PU10 | 2DC8990 | DEV |  |
| F2300 |  | Concept.Design freeze Product Handling | milestone | 0d | 2008-03-08 A | 2008-03-08 A | F2820 FF | 100% |  | F2300 | F2300 | N | 0F | 200 | 200 | 025 | F | 3A | LND | 1 | E | U | 0000 | LUZ2 | 1 | LND |  |  |  |  |  |
| F3690 |  | Concept & Layout Freeze | milestone | 0d | 2008-03-08 A | 2008-03-08 A | F3680 FF+6d | 100% |  | F3690 | F3690 | N | 0F | 200 | 200 | 025 | F | 3A | LND | 1 | E | U | 0000 | LUZ2 | PI | LND |  |  |  |  |  |
| F3700 |  | Phase 1b- Preparation Study |  | 18d | 2008-03-11 A | 2008-04-07 A | F4750 FF, F3690 FS+1d | 100% |  | F3700 | F3700 | N | 0F | 200 | 200 | 025 | F | 3A | LND | 1 | E | U | 0000 | LUZ2 | PI | LND |  |  |  |  |  |
| F10420 |  | PU10 Convey. Syst. - PMT approve Concept |  | 12d | 2008-04-02 A | 2008-04-17 A | F10400 | 100% |  | F10420 | F10420 | 869 | 0F | 200 | 200 | 055 | E | 3A | LND | C2 | E | U | EU13 | LUZ2 | 1 | LND | DC | PU10 | 2DC8990 |  |  |
| F2820 |  | Conveying concept & Layout freeze | milestone | 0d | 2008-04-18 A | 2008-04-18 A | F3430 FF, F3690 FF | 100% |  | F2820 | F2820 | 869 | 0F | 200 | 200 |  |  |  |  |  | E | U | 0000 | LUZ2 | 1 | LND | 90 |  |  |  |  |
| F2830 |  | Phase 2 Product Handling (Basic) |  | 139d | 2008-04-18 A | 2008-11-04 A | F2820 FS+15d | 100% |  | F2830 | F2830 | 869 | 0F | 200 | 200 | 055 | F | 3A | LND |  | E | U | 0000 | LUZ2 | 1 | LND | 90 |  |  |  |  |
| F3710 |  | Decision Gate (Purchaising Strategy) | milestone | 0d | 2008-04-18 A | 2008-04-18 A | F3700 FF+8d | 100% |  | F3710 | F3710 | N | 0F | 200 | 200 | 025 | F | 3A | LND | 1 | E | U | 0000 | LUZ2 | PI | LND |  |  |  |  |  |
| F3720 |  | Phase 2 Product Handling (Basic ) |  | 84d | 2008-04-18 A | 2008-08-15 A | F3710 | 100% |  | F3720 | F3720 | N | 0F | 200 | 200 | 025 | F | 3A | LND | 1 | E | U | 0000 | LUZ2 | PI | LND |  |  |  |  |  |
| F5100 |  | Purchase Orders Downstream completed |  | 22d | 2008-11-05 A | 2008-12-05 A | F2830 | 100% |  | F5100 | F5100 | 869 | 0F | 200 | 200 | 055 | F | 3A | LND |  | E | U | 0000 | LUZ2 | 1 | LND | 90 |  |  |  |  |
| F5000 |  | Phase 2 Product Handling (Detailengineering) |  | 464d | 2008-11-18 A | 2010-09-24 A | F5010 | 100% | TAA [7200 h] | F5000 | F5000 | 869 | 0F | 200 | 200 | 055 | F | 3A | LND |  | E | U | 0000 | LUZ2 | 1 | LND | 90 |  |  |  | 7200,00 |

Notes:
- F1530: P3 Activity Log Info: 7.01
- F1570: P3 Activity Log Info: 7.07
- F1560: P3 Activity Log Info: 7.05
- F1610: P3 Activity Log Info: 9.01
- F1630: P3 Activity Log Info: 9.03
- F1620: P3 Activity Log Info: 9.02
- F1700: P3 Activity Log Info: 9.04
- F1690: P3 Activity Log Info: 11.01

| ID | WBS | Activity | Type | Duration | Start | Finish | Predecessors | Complete | Resources | UDF_SAVE ACTID | UDF_SAVE ACT ID | Department | Constr. Area | PMT-Area | PMT-Schedule Org | PMT-Discipline | PMT-Phase | PMT-Stage | PMT-Respons. | Zeigen/n. Zeigen | WBS Phase | WBS Discipline | WBS Type of Work | WBS Objects | IMS | UPT | Pro Unit/DocCode | Type of Work | Inquiry/Order No | PMT-Doc. Type | TB26 Ressource Budget |
| --- | --- | --- | --- | --- | --- | --- | --- | --- | --- | --- | --- | --- | --- | --- | --- | --- | --- | --- | --- | --- | --- | --- | --- | --- | --- | --- | --- | --- | --- | --- | --- |
|  | B | **B Mechanical - Stationary Equipment** |  |  | 2007-12-10 | 2008-12-17 |  |  |  |  |  |  |  |  |  |  |  |  |  |  |  |  |  |  |  |  |  |  |  |  |  |
| F1660 |  | Mechanical DS, Spec's,RFQ's & PO's LLI |  | 88d | 2007-12-10 A | 2008-04-18 A | F1000 SS | 100% |  | F1660 | F1660 | 869 | 0F | 200 | 200 | 055 | F | 3A | LND | 1 | E | B | 0000 | LUZ2 | 1 | LND |  |  |  |  |  |
| F4780 |  | Mechanical DS --> PO LLI |  | 201d | 2007-12-10 A | 2008-09-26 A | F2180, F2150, F2760, F2160, F2280 | 100% |  | F4780 | F4780 | 869 | 0F | 200 | 200 | 055 | F |  |  |  | E | B | 0000 | LUZ2 | C | LND |  |  |  |  |  |
| F8600 |  | Mechanical DS, Spec's,RFQ's & PO's DCE |  | 137d | 2007-12-20 A | 2008-07-10 A | F2760 | 100% |  | F8600 | F8600 | 869 | 0F | 200 | 200 | 055 | F | 3A | LND | 1 | E | B | 0000 | LUZ2 | E | PMT |  |  |  |  |  |
| F2420 |  | Issue RFQ Reactor/Agitator to PMT/Vendor | milestone | 0d | 2007-12-21 A | 2007-12-21 A | F2760 | 100% |  | F2420 | F2420 | 869 | 0F | 200 | 200 |  | F | 3A | LND | 1 | E | B | 0000 | LUZ2 | 1 | LND |  |  |  |  |  |
| F1680 |  | Equipment List 1st issue |  | 53d | 2008-01-02 A | 2008-03-14 A | F1000 SS | 100% |  | F1680 | F1680 | 869 | 0F | 200 | 200 | 055 | F | 3A | LND | 1 | E | B | 0000 | LUZ2 | 1 | LND |  |  |  |  |  |
| F4490 |  | Vendor Proposal LLI |  | 236d | 2008-01-09 A | 2008-12-12 A | F1540 FF+20d | 100% |  | F4490 | F4490 | 869 | 0F | 200 | 200 |  | F |  | LND |  | E | B | 0000 | LUZ2 |  | LND |  |  |  |  |  |
| F4790 |  | Mechanical DS --> PO Design Critical Equipment |  | 225d | 2008-01-10 A | 2008-11-28 A | F8600 SS | 100% |  | F4790 | F4790 | 869 | 0F | 200 | 200 | 055 | F |  |  |  | E | B | 0000 | LUZ2 | C | LND |  |  |  |  |  |
| F8770 |  | Check Mechanical data sheets/manufacturer doc's |  | 140d | 2008-01-14 A | 2008-07-31 A | F2420 | 100% |  | F8770 | F8770 | 869 | 0F | 200 | 200 | 055 | F | 3A | LND | 1 | E | B | 0000 | LUZ2 | E | PMT |  |  |  |  |  |
| F2430 |  | Issue RFQ Purge Column to PMT/Vendor | milestone | 0d | 2008-01-17 A | 2008-01-17 A | F2760 | 100% |  | F2430 | F2430 | 869 | 0F | 200 | 200 |  | F | 3A | LND | 1 | E | B | 0000 | LUZ2 | 1 | LND |  |  |  |  |  |
| F4340 |  | Standardization Mechanical eng./design standards | milestone | 0d | 2008-01-26 A | 2008-01-26 A | F4320 FF | 100% |  | F4340 | F4340 | 869 | 0F | 200 | 200 |  | F | 3A | PMT | 1 | E | B | 0000 | LUZ2 |  | LND |  |  |  |  |  |
| F1670 |  | Mechanical DS, Spec's,RFQ's -other Equipm |  | 118d | 2008-02-19 A | 2008-08-06 A | F1000 SS | 100% |  | F1670 | F1670 | 869 | 0F | 200 | 200 | 055 | F | 3A | LND | 1 | E | B | 0000 | LUZ2 | 1 | LND |  |  |  |  |  |
| F4500 |  | Vendor Proposal Equip.-critical for plant design |  | 197d | 2008-03-07 A | 2008-12-17 A | F4480 FF+22d | 100% |  | F4500 | F4500 | 869 | 0F | 200 | 200 |  | F |  | LND |  | E | B | 0000 | LUZ2 |  | LND |  |  |  |  |  |
| F1820 |  | Equipment List final issue |  | 91d | 2008-03-17 A | 2008-07-25 A | F1680 | 100% |  | F1820 | F1820 | 869 | 0F | 200 | 200 | 055 | F | 3A | LND | 1 | E | B | 0000 | LUZ2 | 1 | LND |  |  |  |  |  |
| F4760 |  | Preparation cost estimate acc. OBCE Proc. |  | 15d | 2008-05-27 A | 2008-06-16 A | F2450 | 100% |  | F4760 | F4760 | 869 | 0F | 200 | 200 | 055 | F | 3A | LND | 1 | E | B | 0000 | LUZ2 | C | LND |  |  |  |  |  |
| F3260 |  | Vendor Drawings LLI-static equipment | milestone | 0d | 2008-11-03 A | 2008-11-03 A | F2420 | 100% |  | F3260 | F3260 | 869 | 0F | 200 | 200 |  | F |  | LND |  | E | B | 0000 | LUZ2 | PI | LND | 91 |  |  |  |  |
|  | E | **E Electrical** |  |  | 2007-12-10 | 2010-06-08 |  |  |  |  |  |  |  |  |  |  |  |  |  |  |  |  |  |  |  |  |  |  |  |  |  |
| F1930 |  | Electrical Specifications General |  | 127d | 2007-12-10 A | 2008-06-16 A | F2760 | 100% |  | F1930 | F1930 | 874 | 0F | 200 | 200 | 065 | F | 3A | LND | 1 | E | E | EE31 | LUZ2 | 1 | LND |  |  |  |  |  |
| F1940 |  | Electrical Consumers & Motor list preliminary |  | 122d | 2008-01-07 A | 2008-06-30 A | F1930 SS | 100% |  | F1940 | F1940 | 874 | 0F | 200 | 200 | 065 | F | 3A | LND | 1 | E | E | EE31 | LUZ2 | 1 | LND |  |  |  |  |  |
| F1980 |  | Electrical RFQs (main equipment) |  | 63d | 2008-02-29 A | 2008-06-02 A | F1000 SS | 100% |  | F1980 | F1980 | 874 | 0F | 200 | 200 | 065 | F | 3A | LND | 1 | E | E | EE31 | LUZ2 | 1 | LND |  |  |  |  |  |
| E3E1905 |  | E19 Heat Tracing Syst. - Inquiry for cost estimate |  | 8d | 2008-04-21 A | 2008-04-30 A | F8790 SS | 100% |  | E3E1905 | E3E1905 | 874 | 0F | 200 | 200 | 055 | E |  | LND | 0 | E | E | EE39 | LUZ2 | E | LND |  | E19 | 2EB5180 | DEV |  |
| F3650 |  | CA00 General Fire detection system spec by U/I/O |  | 20d | 2008-05-02 A | 2008-05-30 A | F1360 | 100% |  | F3650 | F3650 | 87D | 0F | 200 | 200 | 065 | F | 3A | UIO | 1 | E | E | EE40 | LUZ2 | PI | LND |  |  |  |  |  |
| F8800 |  | CA00 General - Electrical Heat Tracing Design |  | 27d | 2008-05-23 A | 2008-06-30 A | F8790 FF | 100% |  | F8800 | F8800 | 874 | 0F | 200 | 200 | 065 | F | 3A | LND | 1 | E | E | EE80 | LUZ2 | E | PMT |  |  |  |  |  |
| F2000 |  | CA00 General - Fire&Gas detector Layouts byU/I/O |  | 75d | 2008-07-21 A | 2008-11-04 A | F1360 | 100% |  | F2000 | F2000 | 87D | 0F | 200 | 200 | 065 | F | 3A | UIO | 1 | E | E | EE40 | LUZ2 | 1 | LND |  |  |  |  |  |
| E3E1910 |  | E19 Heat Tracing Syst. - Inquiry Spec. |  | 124d | 2009-12-07 A | 2010-06-08 A | E3E1905, F4040 SS | 100% | TAE [2032 h] | E3E1910 | E3E1910 | 87D | 0F | 200 | 200 | 055 | E |  | LND | 0 | E | E | EE39 | LUZ2 | E | LND |  | E19 | 2EB5180 | DEV | 2032,00 |

Notes:
- F1660: P3 Activity Log Info: 10.02
- F4780: P3 Activity Log Info: Gas Bleed Compressor
- F1680: P3 Activity Log Info: 10.04a
- F4790: P3 Activity Log Info: Reactor Gear Box
- F1670: P3 Activity Log Info: 10.03
- F1820: P3 Activity Log Info: 10.04b
- F1930: P3 Activity Log Info: 15.07
- F1940: P3 Activity Log Info: 15.08,15.05
- F1980: P3 Activity Log Info: 15.19
- F3650: P3 Activity Log Info: 12.3
- F8800: P3 Activity Log Info: 15.15
- F2000: P3 Activity Log Info: 16.09

| ID | WBS | Activity | Type | Duration | Start | Finish | Predecessors | Complete | UDF_SAVE ACTID | UDF_SAVE ACT ID | Department | Constr. Area | Pro Unit/DocCode | PMT-Area | PMT-Schedule Org | PMT-Discipline | PMT-Phase | PMT-Stage | PMT-Respons. | Zeigen/n. Zeigen | WBS Phase | WBS Discipline | WBS Type of Work | WBS Objects | IMS | UPT | Type of Work | Inquiry/Order No | PMT-Doc. Type |
| --- | --- | --- | --- | --- | --- | --- | --- | --- | --- | --- | --- | --- | --- | --- | --- | --- | --- | --- | --- | --- | --- | --- | --- | --- | --- | --- | --- | --- | --- |
|  | J | **J Instrumentation** |  |  | 2007-12-10 | 2009-12-11 |  |  |  |  |  |  |  |  |  |  |  |  |  |  |  |  |  |  |  |  |  |  |  |
| F2170 |  | General Design Spec.f.instr.of PU's 2nd issue |  | 126d | 2007-12-10 A | 2008-06-13 A | F3760 FF+10d, F1000 SS | 100% | F2170 | F2170 | 86A | 0F | 999 | 200 | 200 | 070 | F | 3A | LND | 1 | E | J | 0000 | LUZ2 | 1 | LND |  |  |  |
| F3630 |  | AML list for Instrumentation Equipment |  | 12d | 2007-12-10 A | 2007-12-28 A | F1000 SS | 100% | F3630 | F3630 | 86A | 0F | 999 | 200 | 200 | 070 | F | 3A | LND | 1 | E | J | 0000 | LUZ2 | PI | LND |  |  |  |
| F3620 |  | Instrument Documentation List |  | 90d | 2008-01-28 A | 2008-06-05 A | F1000 SS | 100% | F3620 | F3620 | 86A | 0F | 999 | 200 | 200 | 070 | F | 3A | LND | 1 | E | J | 0000 | LUZ2 | PI | LND |  |  |  |
| F2500 |  | Inqiry on/off-& control valves (LLI) |  | 78d | 2008-02-21 A | 2008-06-13 A | F1340 SS+20d, F3630 | 100% | F2500 | F2500 | 86A | 0F | 999 | 200 | 200 | 070 | F | 3A | LND | 1 | E | J | 0000 | LUZ2 | 1 | LND |  |  |  |
| F2600 |  | Specification ESD 1st issue |  | 80d | 2008-02-26 A | 2008-06-20 A | F1000 SS | 100% | F2600 | F2600 | 86A | 0F | 999 | 200 | 200 | 070 | F | 3A | LND | 1 | E | J | 0000 | LUZ2 | 1 | LND |  |  |  |
| F1990 |  | Instrument Index for cost estimate |  | 68d | 2008-02-28 A | 2008-06-06 A | F2230, F1000 SS, F1340 FF+30d | 100% | F1990 | F1990 | 86A | 0F | 999 | 200 | 200 | 070 | F | 3A | LND | 1 | E | J | 0000 | LUZ2 | 1 | LND |  |  |  |
| F2540 |  | Cable tray concept(incl.cable tray distr.draw.) |  | 44d | 2008-03-12 A | 2008-05-16 A | F1780 FF+12d | 100% | F2540 | F2540 | 86A | 0F | 999 | 200 | 200 | 070 | F | 3A | LND | 1 | E | J | 0000 | LUZ2 | 1 | LND |  |  |  |
| E3J02B10 |  | J02B Knife Valves - Inquiry Spec. |  | 8d | 2008-03-13 A | 2008-03-26 A | F2500 SS, F2170 SS | 100% | E3J02B10 | E3J02B10 | 86B | 0F | 999 | 200 | 200 | 055 | E |  | LND | 0 | E | J | EJ33 | LUZ2 | PI | LND | J02B | 2AJ3000 | DEV |
| E3J02D10 |  | J02D ON/OFF Plug Valves - Inquiry Spec. |  | 8d | 2008-03-13 A | 2008-03-26 A | F2500 SS | 100% | E3J02D10 | E3J02D10 | 86B | 0F | 999 | 200 | 200 | 055 | E |  | LND | 0 | E | J | EJ33 | LUZ2 | PI | LND | J02D | 2AJ3020 | DEV |
| E3J0210 |  | J02 Control Valves - Inquiry Spec. |  | 7d | 2008-03-14 A | 2008-03-26 A | F2500 SS | 100% | E3J0210 | E3J0210 | 86B | 0F | 999 | 200 | 200 | 055 | E |  | LND | 0 | E | J | EJ33 | LUZ2 | OTH | LND | J02 | 2AJ3030 | DEV |
| E3J0510 |  | J05 MPS/CMS - Inquiry Spec. |  | 25d | 2008-03-17 A | 2008-04-22 A | F2600 SS+10d | 100% | E3J0510 | E3J0510 | 86C | 0F | 999 | 200 | 200 | 055 | E |  | LND | 0 | E | J | EJ23 | LUZ2 | I | LND | J05 | 2JD7520 | DEV |
| E3J0602 |  | J06 Safety Instr.Syst. SIS - Inquiry Spec. |  | 26d | 2008-03-17 A | 2008-04-23 A | F2600 SS | 100% | E3J0602 | E3J0602 | 86C | 0F | 999 | 200 | 200 | 055 | E |  | LND | 0 | E | J | EJ23 | LUZ2 | I | LND | J06 | 2JD9220 | DEV |
| F2620 |  | Concept FBD's |  | 61d | 2008-03-17 A | 2008-06-13 A | F2600 FF | 100% | F2620 | F2620 | 86A | 0F | 999 | 200 | 200 | 070 | F | 3A | LND | 1 | E | J | 0000 | LUZ2 | 1 | LND |  |  |  |
| F2630 |  | Concept Loop's |  | 72d | 2008-03-17 A | 2008-06-30 A | F2620 FF | 100% | F2630 | F2630 | 86A | 0F | 999 | 200 | 200 | 070 | F | 3A | LND | 1 | E | J | 0000 | LUZ2 | 1 | LND |  |  |  |
| E3J01A10 |  | J01A Ball Valves - Inquiry Spec. |  | 9d | 2008-03-18 A | 2008-04-01 A | F2170 SS, F2500 SS | 100% | E3J01A10 | E3J01A10 | 86B | 0F | 999 | 200 | 200 | 055 | E |  | LND | 0 | E | J | EJ33 | LUZ2 | OTH | LND | J01A | 2AJ2610 | DEV |
| E3J04A10 |  | J04A Coriolis Mass Flowmeter - Inquiry Spec. |  | 10d | 2008-03-18 A | 2008-04-02 A | F2570 SS-20d | 100% | E3J04A10 | E3J04A10 | 86B | 0F | 999 | 200 | 200 | 055 | E |  | LND | 0 | E | J | EJ33 | LUZ2 | PI | LND | J04A | 2JD7280 | DEV |
| E3J04B10 |  | J04B Vortex Flowmeter - Inquiry Spec. |  | 9d | 2008-03-19 A | 2008-04-02 A | F2570 SS+30d | 100% | E3J04B10 | E3J04B10 | 86B | 0F | 999 | 200 | 200 | 055 | E |  | LND | 0 | E | J | EJ33 | LUZ2 | PI | LND | J04B | 2JD9260 | DEV |
| E3J0110 |  | J01 Ball Valves PDS - Inquiry Spec. |  | 7d | 2008-03-25 A | 2008-04-02 A | F2170 SS, F2500 SS | 100% | E3J0110 | E3J0110 | 86B | 0F | 999 | 200 | 200 | 055 | E |  | LND | 0 | E | J | EJ33 | LUZ2 | OTH | LND | J01 | 2AJ2620 | DEV |
| E3J02A10 |  | J02A PCV Valves - Inquiry Spec. |  | 12d | 2008-04-01 A | 2008-04-16 A | F2500 SS+25d | 100% | E3J02A10 | E3J02A10 | 86B | 0F | 999 | 200 | 200 | 055 | E |  | LND | 0 | E | J | EJ33 | LUZ2 | OTH | LND | J02A | 2AJ2660 | DEV |
| E3J02C10 |  | J02C Butterfly Valves on/off - Inquiry Spec. |  | 13d | 2008-04-03 A | 2008-04-21 A | F2170 SS, F2500 SS+25d | 100% | E3J02C10 | E3J02C10 | 86B | 0F | 999 | 200 | 200 | 055 | E |  | LND | 0 | E | J | EJ33 | LUZ2 | PI | LND | J02C | 2AJ3090 | DEV |
| E3J04E10 |  | J04E Var.Area Flow.(Rotam.) - Inquiry Spec. |  | 9d | 2008-04-07 A | 2008-04-17 A | F2570 SF-5d | 100% | E3J04E10 | E3J04E10 | 86B | 0F | 999 | 200 | 200 | 055 | E |  | LND | 0 | E | J | EJ33 | LUZ2 | I | LND | J04E | 2JD7330 | DEV |
| E3J0310 |  | J03 Nuclear Level Measurement - Inquiry Spec. |  | 10d | 2008-04-11 A | 2008-04-24 A | F2570 SF, F2170 SS | 100% | E3J0310 | E3J0310 | 86B | 0F | 999 | 200 | 200 | 055 | E |  | LND | 0 | E | J | EJ33 | LUZ2 | PI | LND | J03 | 2JD7540 | DEV |
| F2530 |  | RIE Layout Drawing |  | 54d | 2008-04-14 A | 2008-06-30 A | F1990 FF, F2630 FF | 100% | F2530 | F2530 | 86A | 0F | 999 | 200 | 200 | 070 | F | 3A | LND | 1 | E | J | 0000 | LUZ2 | 1 | LND |  |  |  |
| E3J0710 |  | J07 Analyser System - Inquiry Spec. |  | 13d | 2008-04-21 A | 2008-05-08 A | F2600 SS+45d | 100% | E3J0710 | E3J0710 | 86B | 0F | 999 | 200 | 200 | 055 | E |  | LND | 0 | E | J | EJ33 | LUZ2 | I | LND | J07 | 2JD7560 | DEV |
| F2570 |  | Inquiry of field instruments (LLI) |  | 24d | 2008-04-25 A | 2008-05-30 A | F1340 FF+10d, F2500 FF | 100% | F2570 | F2570 | 86A | 0F | 999 | 200 | 200 | 070 | F | 3A | LND | 1 | E | J | 0000 | LUZ2 | 1 | LND |  |  |  |
| F2520 |  | Special Instrumentation Description |  | 20d | 2008-05-02 A | 2008-05-30 A | F1990 FF+16d | 100% | F2520 | F2520 | 86A | 0F | 999 | 200 | 200 | 070 | F | 3A | LND | 1 | E | J | 0000 | LUZ2 | 1 | LND |  |  |  |
| F2560 |  | Specification of cables |  | 41d | 2008-05-02 A | 2008-06-30 A | F1990 FF | 100% | F2560 | F2560 | 86A | 0F | 999 | 200 | 200 | 070 | F | 3A | LND | 1 | E | J | 0000 | LUZ2 | 1 | LND |  |  |  |
| F8940 |  | Input Instrument. for Structural Steel Design | milestone | 0d | 2008-05-16 A | 2008-05-16 A | F2540 | 100% | F8940 | F8940 | 86A | 0F | 999 | 200 | 200 | 070 | F | 3A | LND | 1 | E | J | 0000 | LUZ2 | E | PMT |  |  |  |
| E3J0320 |  | J03 Nuclear Level Meas. - Techn. Eval./PO Spec |  | 19d | 2008-05-19 A | 2008-06-12 A | P3J03B FS+11d | 100% | E3J0320 | E3J0320 | 86B | 0F | 999 | 200 | 200 | 055 | E |  | LND | 0 | E | J | EJ34 | LUZ2 | PI | LND | J03 | 2JD7540 |  |
| F8810 |  | Preparation cost estimate acc. OBCE Proc. |  | 20d | 2008-05-20 A | 2008-06-16 A | F2500 SS | 100% | F8810 | F8810 | 86A | 0F | 999 | 200 | 200 |  | F | 3A | LND | 1 | E | J | 0000 | LUZ2 | E | PMT |  |  |  |
| F2400 |  | Instrument Index FEED |  | 29d | 2008-05-21 A | 2008-06-30 A | F3930 FF+41d, F2390 FF+21d | 100% | F2400 | F2400 | 86A | 0F | 999 | 200 | 200 | 070 | F | 3A | LND | 1 | E | J | 0000 | LUZ2 | 1 | LND |  |  |  |
| F2010 |  | Interface Requirements Description |  | 26d | 2008-05-26 A | 2008-06-30 A | F2400 FF | 100% | F2010 | F2010 | 86A | 0F | 999 | 200 | 200 | 070 | F | 3A | LND | 1 | E | J | 0000 | LUZ2 | 1 | LND |  |  |  |
| E3J0330 |  | J03 Nuclear Level Meas. -Techn.Eval./Bid Tab | milestone | 0d | 2008-05-27 A | 2008-05-27 A | E3J0315 SF, E3J0320 FF-14d | 100% | E3J0330 | E3J0330 | 86B | 0F | 999 | 200 | 200 | 055 | E |  | LND | 0 | E | J | EJ34 | LUZ2 | PI | LND | J03 | 2JD7540 |  |
| F3760 |  | SIBUR Standards+Spec.'s Instrumentation-PMT | milestone | 0d | 2008-06-14 A | 2008-06-14 A | F3550 FF | 100% | F3760 | F3760 | 86A | 0F | 999 | 200 | 200 | 070 | F | 3A | PMT | 1 | E | J | 0000 | LUZ2 | PI | LND |  |  |  |
| F3910 |  | Instrumentation & Control Design Basis-PMT | milestone | 0d | 2008-06-14 A | 2008-06-14 A | F3540 FF | 100% | F3910 | F3910 | 86A | 0F | 999 | 200 | 200 | 070 | F | 3A | PMT | 1 | E | J | 0000 | LUZ2 | PI | LND |  |  |  |
| F3900 |  | Automation Functional Requirement Spec.-PMT | milestone | 0d | 2008-06-28 A | 2008-06-28 A | F2760 | 100% | F3900 | F3900 | 86A | 0F | 999 | 200 | 200 | 070 | F | 3A | PMT | 1 | E | J | 0000 | LUZ2 | PI | LND |  |  |  |
| F4200 |  | Standardization f. Instrumentation eng./design | milestone | 0d | 2008-06-28 A | 2008-06-28 A | F4190 FF | 100% | F4200 | F4200 | 86A | 0F | 999 | 200 | 200 | 070 | F | 3A | PMT | 1 | E | J | 0000 | LUZ2 |  | LND |  |  |  |
| F3770 |  | Analyzer Shelter Design Criteria FREEZE | milestone | 0d | 2008-10-01 A | 2008-10-01 A | F2760 | 100% | F3770 | F3770 | 86A | 0F | 999 | 200 | 200 | 070 | F | 3A | PMT | 1 | E | J | 0000 | LUZ2 | PI | LND |  |  |  |
| E3J04I10 |  | J04I Ultrasonic Flowm. - Inquiry Spec. |  | 15d | 2009-01-26 A | 2009-02-13 A | F2570 SS+115d | 100% | E3J04I10 | E3J04I10 | 86B | 0F | 999 | 200 | 200 | 055 | E |  | LND | 0 | E | J | EJ33 | LUZ2 | I | LND | J04I | 2JD8500 | DEV |
| E3J0610 |  | J06 DCS / SIS - Verification / Prepare PO Spec. (FEED) |  | 45d | 2009-08-24 A | 2009-10-23 A | E3J0604, F2600 SS, E3J0606 | 100% | E3J0610 | E3J0610 | 86C | 0F | 999 | 200 | 200 | 055 | E |  | LND | 0 | E | J | EJ23 | LUZ2 | I | LND | J06 | 2JD9220 | DEV |
| E3J0612 |  | J06 DCS / SIS - Inquiry Spec. |  | 26d | 2009-10-16 A | 2009-11-23 A | E3J0610 SS+39d | 100% | E3J0612 | E3J0612 | 86C | 0F | 999 | 200 | 200 | 055 | E |  | LND | 0 | E | J | EJ23 | LUZ2 | I | LND | J06 | 2JD9220 | DEV |
| E3J0614 |  | J06 DCS / SIS - Inquiry Spec. - Client approval |  | 14d | 2009-11-24 A | 2009-12-11 A | E3J0612 | 100% | E3J0614 | E3J0614 | 86C | 0F | 999 | 200 | 200 | 055 | E |  | PMT | 0 | E | J | EJ23 | LUZ2 | I | LND | J06 | 2JD9220 | DEV |

Notes:
- F2500: P3 Activity Log Info: 16.11
- F2600: P3 Activity Log Info: 16.05
- F1990: P3 Activity Log Info: 16.08a
- F2540: P3 Activity Log Info: 16.13
- F2530: P3 Activity Log Info: 16.06,16.07
- F2570: P3 Activity Log Info: 16.11, 16.21, 16.22, 16.28
- F2520: P3 Activity Log Info: 16.3
- F2560: P3 Activity Log Info: 16.15
- F2400: P3 Activity Log Info: 16.08b
- F2010: P3 Activity Log Info: 16.10

| ID | WBS | Activity | Type | Duration | Start | Finish | Predecessors | Complete | UDF_SAVE ACTID | UDF_SAVE ACT ID | Department | Constr. Area | PMT-Area | PMT-Schedule Org | PMT-Discipline | PMT-Phase | PMT-Stage | PMT-Respons. | Zeigen/n. Zeigen | WBS Phase | WBS Discipline | WBS Type of Work | WBS Objects | IMS | UPT | Pro Unit/DocCode |
| --- | --- | --- | --- | --- | --- | --- | --- | --- | --- | --- | --- | --- | --- | --- | --- | --- | --- | --- | --- | --- | --- | --- | --- | --- | --- | --- |
|  | M | **M Mechanical - Rotating Equipment** |  |  | 2007-12-10 | 2008-11-17 |  |  |  |  |  |  |  |  |  |  |  |  |  |  |  |  |  |  |  |  |
| F1640 |  | Mechanical DS, Spec's,RFQ's & PO's LLI |  | 186d | 2007-12-10 A | 2008-09-05 A | F1000 SS | 100% | F1640 | F1640 | 867 | 0F | 200 | 200 | 055 | F | 3A | LND | 1 | E | M | 0000 | LUZ2 | 1 | LND |  |
| F3330 |  | RFQ's LLI -rotating equipment |  | 226d | 2007-12-21 A | 2008-11-17 A | F2760 | 100% | F3330 | F3330 | 867 | 0F | 200 | 200 |  | F |  | LND | 3 | E | M | 0000 | LUZ2 | PI | LND |  |
| F2470 |  | Issue RFQ Off Gas Compr. to PMT/Vendor | milestone | 0d | 2008-01-08 A | 2008-01-08 A | F2760 | 100% | F2470 | F2470 | 867 | 0F | 200 | 200 |  | F | 3A | LND | 1 | E | M | 0000 | LUZ2 | 1 | LND |  |
| F2460 |  | Issue RFQ Extruder to PMT/Vendor | milestone | 0d | 2008-01-12 A | 2008-01-12 A | F2760 | 100% | F2460 | F2460 | 867 | 0F | 200 | 200 |  | F | 3A | LND | 1 | E | M | 0000 | LUZ2 | 1 | LND |  |
| F2480 |  | Issue RFQ Recycle Gas Compr. to PMT/Vendor | milestone | 0d | 2008-01-17 A | 2008-01-17 A | F2760 | 100% | F2480 | F2480 | 867 | 0F | 200 | 200 |  | F | 3A | LND | 1 | E | M | 0000 | LUZ2 | 1 | LND |  |
| F4330 |  | Standardization Mechanical eng./design standards | milestone | 0d | 2008-01-26 A | 2008-01-26 A | F4320 FF | 100% | F4330 | F4330 | 867 | 0F | 200 | 200 |  | F | 3A | PMT | 1 | E | M | 0000 | LUZ2 |  | LND |  |
| F8740 |  | Mechanical DS, Spec's,RFQ's & PO's DCE |  | 131d | 2008-02-06 A | 2008-08-12 A | F2480, F2490 FF, F4330, F2470 | 100% | F8740 | F8740 | 867 | 0F | 200 | 200 | 055 | F | 3A | LND | 1 | E | M | 0000 | LUZ2 | E | PMT |  |
| F1650 |  | Mechanical DS, Spec's,RFQ's -other Equipment |  | 107d | 2008-02-15 A | 2008-07-18 A | F1000 SS | 100% | F1650 | F1650 | 867 | 0F | 200 | 200 | 055 | F | 3A | LND | 1 | E | M | 0000 | LUZ2 | 1 | LND |  |
| F8780 |  | Mechanical DS, Techn. bid comp. -other Equipment |  | 141d | 2008-04-14 A | 2008-10-30 A | M3T100 FF, F1650 FF+30d | 100% | F8780 | F8780 | 867 | 0F | 200 | 200 | 055 | F | 3A | LND | 1 | E | M | 0000 | LUZ2 | E | PMT |  |
| F2490 |  | Issue RFQ Gas Bleed Booster to PMT/Vendor | milestone | 0d | 2008-05-16 A | 2008-05-16 A | P3M04A FS-5d | 100% | F2490 | F2490 | 867 | 0F | 200 | 200 | 055 | F | 3A | LND | 1 | E | M | 0000 | LUZ2 | 1 | LND |  |
| F9050 |  | Preparation cost estimate acc. OBCE Proc. |  | 15d | 2008-05-27 A | 2008-06-16 A | F2450 | 100% | F9050 | F9050 | 867 | 0F | 200 | 200 | 055 | F | 3A | LND | 1 | E | M | 0000 | LUZ2 | E | PMT |  |
|  | R | **R Piping** |  |  | 2008-01-28 | 2008-06-20 |  |  |  |  |  |  |  |  |  |  |  |  |  |  |  |  |  |  |  |  |
| F1750 |  | Piping Specifications prel. |  | 49d | 2008-01-28 A | 2008-04-07 A | F8700, F1000 SS, F2610 | 100% | F1750 | F1750 | 873 | 0F | 200 | 200 | 085 | F | 3A | LND | 1 | E | R | ER00 | LUZ2 | 1 | LND |  |
| F1830 |  | Piping Service Index prel. |  | 49d | 2008-01-28 A | 2008-04-07 A | F1000 SS, F1750 FF | 100% | F1830 | F1830 | 873 | 0F | 200 | 200 | 085 | F | 3A | LND | 1 | E | R | ER00 | LUZ2 | 1 | LND |  |
| F4390 |  | Standardization Piping eng./design standards | milestone | 0d | 2008-03-04 A | 2008-03-04 A | F4380 FF | 100% | F4390 | F4390 | 873 | 0F | 200 | 200 | 085 | F | 3A | PMT | 1 | E | R | ER00 | LUZ2 |  | LND |  |
| F2650 |  | Piping Service Index final |  | 47d | 2008-03-25 A | 2008-05-30 A | F2640 FF | 100% | F2650 | F2650 | 873 | 0F | 200 | 200 | 085 | F | 3A | LND | 1 | E | R | ER00 | LUZ2 | 1 | LND |  |
| F8630 |  | MTO for Inquiry Piping bulk |  | 5d | 2008-04-22 A | 2008-04-28 A | F2390 | 100% | F8630 | F8630 | 873 | 0F | 200 | 200 | 085 | F | 3A | LND | 1 | E | R | ER00 | LUZ2 | E | PMT |  |
| F1840 |  | MTO for Inquiry Valves/ Fittings |  | 5d | 2008-04-23 A | 2008-04-29 A | F2390 | 100% | F1840 | F1840 | 873 | 0F | 200 | 200 | 085 | F | 3A | LND | 1 | E | R | ER00 | LUZ2 | 1 | LND |  |
| F2640 |  | Piping Specifications final |  | 37d | 2008-04-29 A | 2008-06-20 A | F1750 FS+15d | 100% | F2640 | F2640 | 873 | 0F | 200 | 200 | 085 | F | 3A | LND | 1 | E | R | ER00 | LUZ2 | 1 | LND |  |
| F8640 |  | Preparation cost estimate for Valves/ Fittings |  | 36d | 2008-04-29 A | 2008-06-19 A | F1840 FF+5d | 100% | F8640 | F8640 | 873 | 0F | 200 | 200 | 085 | F | 3A | LND | 1 | E | R | ER00 | LUZ2 | E | PMT |  |
| F8650 |  | Preparation cost estimate for Piping Bulk |  | 36d | 2008-04-29 A | 2008-06-19 A | F8630 FF+5d | 100% | F8650 | F8650 | 873 | 0F | 200 | 200 | 085 | F | 3A | LND | 1 | E | R | ER00 | LUZ2 | E | PMT |  |
| F9020 |  | Preparation cost estimate acc. OBCE Proc. |  | 18d | 2008-05-27 A | 2008-06-19 A | F2760 | 100% | F9020 | F9020 | 873 | 0F | 200 | 200 | 050 | F | 3A | LND | 1 | E | R | ER00 | LUZ2 | E | PMT |  |
|  | S | **S Safety & Environment** |  |  | 2007-12-28 | 2009-02-14 |  |  |  |  |  |  |  |  |  |  |  |  |  |  |  |  |  |  |  |  |
| F1040 |  | HSE Mangement System Plan |  | 138d | 2007-12-28 A | 2008-07-16 A | F2760 | 100% | F1040 | F1040 | 871 | 0F | 200 | 200 | 080 | F | 3A | LND | 1 | E | S | 0000 | LUZ2 | 1 | LND |  |
| F1350 |  | Environmental Protection Concept |  | 66d | 2008-01-16 A | 2008-04-18 A | F1000 SS, F1810, F2260 | 100% | F1350 | F1350 | 871 | 0F | 200 | 200 | 080 | F | 3A | LND | 1 | E | S | 0000 | LUZ2 | 1 | LND |  |
| F1380 |  | Explosion Protection/Hazardous Area Class. Conc. |  | 60d | 2008-01-24 A | 2008-04-18 A | F1810, F1000 SS | 100% | F1380 | F1380 | 871 | 0F | 200 | 200 | 080 | F | 3A | LND | 1 | E | S | 0000 | LUZ2 | 1 | LND |  |
| F1420 |  | Fire Protection Concept |  | 52d | 2008-01-29 A | 2008-04-11 A | F1810, F2260 | 100% | F1420 | F1420 | 871 | 0F | 200 | 200 | 045 | F | 3A | LND | 1 | E | S | 0000 | LUZ2 | 1 | LND |  |
| F2580 |  | Definition of Mechanical Design Data for Spec's |  | 26d | 2008-02-04 A | 2008-03-10 A | F2260, F1000 SS, F4430 | 100% | F2580 | F2580 | 871 | 0F | 200 | 200 | 080 | F | 3A | LND | 1 | E | S | 0000 | LUZ2 | 1 | LND |  |
| F1370 |  | SIL Assignment & Verification Report |  | 70d | 2008-02-18 A | 2008-05-29 A | F2260, F8700, F4430 | 100% | F1370 | F1370 | 871 | 0F | 200 | 200 | 080 | F | 3A | LND | 1 | E | S | 0000 | LUZ2 | 1 | LND |  |
| F1260 |  | Relief Valve calculations |  | 87d | 2008-02-25 A | 2008-06-30 A | F1340 SS+16d, F1000 SS, F2270 | 100% | F1260 | F1260 | 871 | 0F | 200 | 200 | 080 | F | 3A | LND | 1 | E | S | 0000 | LUZ2 | 1 | LND |  |
| F1410 |  | Consequence/Blast Risk Assessment N/A |  | 72d | 2008-02-29 A | 2008-06-13 A | F2260, F1810 | 100% | F1410 | F1410 | 871 | 0F | 200 | 200 | 080 | F | 3A | LND | 1 | E | S | 0000 | LUZ2 | 1 | LND |  |
| F3840 |  | Hazard/Safety Review/Report (part of PDP) | milestone | 0d | 2008-02-29 A | 2008-02-29 A | F3640 FF | 100% | F3840 | F3840 | 871 | 0F | 200 | 200 |  | F | 3A | INE | 1 | E | S | 0000 | LUZ2 | PI | LND |  |
| F8730 |  | HAZID |  | 2d | 2008-04-03 A | 2008-04-04 A | F2370, F3600 FS-7d | 100% | F8730 | F8730 | 871 | 0F | 200 | 200 | 080 | F | 3A | LND | 1 | E | S | 0000 | LUZ2 | E | PMT |  |
| F1360 |  | Gas detector location drawings |  | 31d | 2008-05-09 A | 2008-06-23 A | F1780 | 100% | F1360 | F1360 | 871 | 0F | 200 | 200 | 045 | F | 3A | LND | 1 | E | S | 0000 | LUZ2 | 1 | LND |  |
| F1850 |  | Fire Fighting Plotplan |  | 31d | 2008-05-09 A | 2008-06-23 A | F1000 SS, F1780, F2260 | 100% | F1850 | F1850 | 871 | 0F | 200 | 200 | 045 | F | 3A | LND | 1 | E | S | 0000 | LUZ2 | 1 | LND |  |
| F1920 |  | Area Classification Drawings |  | 31d | 2008-05-09 A | 2008-06-23 A | F1000 SS, F2260, F1780 | 100% | F1920 | F1920 | 871 | 0F | 200 | 200 | 080 | F | 3A | LND | 1 | E | S | 0000 | LUZ2 | 1 | LND |  |
| F2320 |  | Flare Load Summary |  | 27d | 2008-05-23 A | 2008-06-30 A | F2390 FF+15d, F3930 FF+15d, F1260 FF | 100% | F2320 | F2320 | 871 | 0F | 200 | 200 | 080 | F | 3A | LND | 1 | E | S | 0000 | LUZ2 | 1 | LND |  |
| F9030 |  | Preparation cost estimate acc. OBCE Proc. |  | 15d | 2008-05-27 A | 2008-06-16 A | F2450 | 100% | F9030 | F9030 | 871 | 0F | 200 | 200 | 045 | F | 3A | LND | 1 | E | S | 0000 | LUZ2 | E | PMT |  |
| F3050 |  | HAZOP (Licensor's Package+Utilities upstream) |  | 20d | 2008-06-02 A | 2008-06-27 A | AD1300 FF | 100% | F3050 | F3050 | 871 | 0F | 200 | 200 |  |  |  | LND |  | E | S | 0000 | LUZ2 | E | LND | 91 |
| F8710 |  | update of Plotplan/Area rel. Drwgs. |  | 83d | 2008-06-06 A | 2008-09-30 A | F2510 FF | 100% | F8710 | F8710 | 871 | 0F | 200 | 200 |  | F | 3A | LND | 1 | E | S | 0000 | LUZ2 | E | PMT |  |
| AD1340 |  | Project Spec./Typicals for Safety Material | milestone | 0d | 2008-11-04 A | 2008-11-04 A | F2765 FF | 100% | AD1340 | AD1340 | 871 | 0F | 200 | 200 | 080 | AD | 3A | PMT | 1 | E | S | 0000 | LUZ2 | INS | LND |  |
| F4430 |  | Standardization Safety eng./design standards | milestone | 0d | 2008-11-04 A | 2008-11-04 A | F4420 FF | 100% | F4430 | F4430 | 871 | 0F | 200 | 200 | 080 | F | 3A | PMT | 1 | E | S | 0000 | LUZ2 |  | LND |  |
| AD1350 |  | Proj. Spec./Typicals f. Minor FF Eq./Hydrants | milestone | 0d | 2009-02-14 A | 2009-02-14 A | E3S0810 | 100% | AD1350 | AD1350 | 871 | 0F | 200 | 200 | 080 | AD | 3A | PMT | 1 | E | S | 0000 | LUZ2 | INS | LND |  |

Notes:
- F1640: P3 Activity Log Info: 10.02
- F1650: P3 Activity Log Info: 10.03
- F9050: Expenses: 875H 0
- F1750: P3 Activity Log Info: 14.02a
- F1830: P3 Activity Log Info: 14.12a
- F2650: P3 Activity Log Info: 14.12b
- F2640: P3 Activity Log Info: 14.02b
- F1040: P3 Activity Log Info: 2.05
- F1350: P3 Activity Log Info: 5.05
- F1380: P3 Activity Log Info: 5.09
- F1420: P3 Activity Log Info: 5.15,12.01,12.03,12.04,12.05
- F1370: P3 Activity Log Info: 5.08
- F1260: P3 Activity Log Info: cb/15:05:11:
- F1410: P3 Activity Log Info: 5.14
- F1360: P3 Activity Log Info: 12.05
- F1850: P3 Activity Log Info: 14.23,14.24
- F1920: P3 Activity Log Info: 15.06

| ID | WBS | Activity | Type | Duration | Start | Finish | Predecessors | Complete | UDF_SAVE ACTID | UDF_SAVE ACT ID | Department | Constr. Area | PMT-Area | PMT-Schedule Org | PMT-Discipline | PMT-Phase | PMT-Stage | PMT-Respons. | Zeigen/n. Zeigen | WBS Phase | WBS Discipline | WBS Type of Work | WBS Objects | IMS | UPT |
| --- | --- | --- | --- | --- | --- | --- | --- | --- | --- | --- | --- | --- | --- | --- | --- | --- | --- | --- | --- | --- | --- | --- | --- | --- | --- |
|  | W | **W Painting** |  |  | 2007-12-18 | 2008-05-16 |  |  |  |  |  |  |  |  |  |  |  |  |  |  |  |  |  |  |  |
| F1860 |  | Painting, Coatings Specification |  | 100d | 2007-12-18 A | 2008-05-16 A | F1000 SS+6d | 100% | F1860 | F1860 | 883 | 0F | 200 | 200 | 055 | F | 3A | LND | 1 | E | W | 0000 | LUZ2 | 1 | LND |
|  | V | **V Insulation** |  |  | 2008-06-23 | 2008-11-14 |  |  |  |  |  |  |  |  |  |  |  |  |  |  |  |  |  |  |  |
| F1870 |  | Insulation Specification |  | 103d | 2008-06-23 A | 2008-11-14 A | F3670 FS-15d | 100% | F1870 | F1870 | 934 | 0F | 200 | 200 | 500 | F | 3A | PMT | 1 | E | V | 0000 | LUZ2 | 1 | LND |
|  | Q | **Q Quality Planning/ Qualtity Assurance** |  |  | 2007-12-10 | 2008-11-04 |  |  |  |  |  |  |  |  |  |  |  |  |  |  |  |  |  |  |  |
| F1450 |  | Reg. f. design/insp./testing of pressure vessels |  | 131d | 2007-12-10 A | 2008-06-20 A | F1000 SS | 100% | F1450 | F1450 | 883 | 0F | 200 | 200 | 055 | F | 3A | LND | 1 | E | Q | 0000 | LUZ2 | 1 | LND |
| F3730 |  | Environmental Data& Design Basis for Calc. |  | 62d | 2008-01-02 A | 2008-03-31 A | F1000 SS+7d | 100% | F3730 | F3730 | 883 | 0F | 200 | 200 | 055 | F | 3A | LND | 1 | E | Q | 0000 | LUZ2 | PI | LND |
| F1050 |  | Quality Audit Plan |  | 62d | 2008-02-01 A | 2008-04-30 A | F1000 SS+20d | 100% | F1050 | F1050 | 883 | 0F | 200 | 200 | 055 | F | 3A | LND | 1 | E | Q | 0000 | LUZ2 | 1 | LND |
| F1490 |  | Reg. f. design/insp./testing of Package Units |  | 102d | 2008-02-01 A | 2008-06-27 A | F1000 SS+14d | 100% | F1490 | F1490 | 883 | 0F | 200 | 200 | 055 | F | 3A | LND | 1 | E | Q | 0000 | LUZ2 | 1 | LND |
| F1300 |  | Material Selection Diagram (piping) |  | 93d | 2008-03-14 A | 2008-07-28 A | F2760 | 100% | F1300 | F1300 | 883 | 0F | 200 | 200 | 055 | F | 3A | LND | 1 | E | Q | 0000 | LUZ2 | 1 | LND |
| F3750 |  | Purchase spec. for piping components |  | 68d | 2008-03-25 A | 2008-06-30 A | F1340 FS-10d | 100% | F3750 | F3750 | 883 | 0F | 200 | 200 | 055 | F | 3A | LND | 1 | E | Q | 0000 | LUZ2 | PI | LND |
| F1480 |  | Reg. f. design/insp./testing for piping |  | 88d | 2008-03-28 A | 2008-07-31 A | F3480, F1000 SS+45d | 100% | F1480 | F1480 | 883 | 0F | 200 | 200 | 055 | F | 3A | LND | 1 | E | Q | 0000 | LUZ2 | 1 | LND |
| F1060 |  | Quality Audit Reports |  | 25d | 2008-05-27 A | 2008-06-30 A | F1050, F1000 SS | 100% | F1060 | F1060 | 883 | 0F | 200 | 200 | 055 | F | 3A | LND | 1 | E | Q | 0000 | LUZ2 | 1 | LND |
| F3860 |  | Applicable Regulations/Standards-Gouv./PMT | milestone | 0d | 2008-05-31 A | 2008-05-31 A | F3480 FF | 100% | F3860 | F3860 | 883 | 0F | 200 | 200 | 055 | F | 3A | PMT | 1 | E | Q | 0000 | LUZ2 | PI | LND |
| F3830 |  | Results about GOST-R-CERTIFICAT-Gouv./PMT | milestone | 0d | 2008-11-04 A | 2008-11-04 A | F3490 FF | 100% | F3830 | F3830 | 883 | 0F | 200 | 200 | 055 | F | 3A | PMT | 1 | E | Q | 0000 | LUZ2 | PI | LND |
|  | LUZ1 | **LUZ1 Lutz Kern - Procurement** |  |  | 2008-03-17 | 2009-03-13 |  |  |  |  |  |  |  |  |  |  |  |  |  |  |  |  |  |  |  |
|  | L | **L Plant Design** |  |  | 2008-03-17 | 2009-03-13 |  |  |  |  |  |  |  |  |  |  |  |  |  |  |  |  |  |  |  |
| F2730 |  | Design Criteria of Pipe Stress Analysis |  | 54d | 2008-03-17 A | 2008-06-04 A | F1340 | 100% | F2730 | F2730 | 872 | 0F | 200 | 200 | 085 | F | 3A | LND | 1 | E | L | 0000 | LUZ1 | 1 | LND |
| F1790 |  | 3D PDS Model Set up and Usage procedures |  | 46d | 2008-04-24 A | 2008-06-30 A | F1830, F1750, F1000 SS | 100% | F1790 | F1790 | 876 | 0F | 200 | 200 | 050 | F | 3A | LND | 1 | E | L | 0000 | LUZ1 | 1 | LND |
| F2590 |  | Area Plot/ Arrangement Plans |  | 89d | 2008-04-25 A | 2008-08-29 A | F1780 | 100% | F2590 | F2590 | 876 | 0F | 200 | 200 | 050 | F | 3A | LND | 1 | E | L | 0000 | LUZ1 | 1 | LND |
| F8970 |  | Release Bulk Material (Offer) supp. f. TKR |  | 17d | 2008-05-07 A | 2008-05-30 A | F8640 FS-5d, F8650 FS-5d | 100% | F8970 | F8970 | 876 | 0F | 200 | 200 | 050 | F | 3A | LND | 1 | E | L | 0000 | LUZ1 | E | PMT |
| F2510 |  | Plot Plans 2nd issue (FEED) |  | 80d | 2008-05-09 A | 2008-08-29 A | F1780 | 100% | F2510 | F2510 | 876 | 0F | 200 | 200 | 050 | F | 3A | LND | 1 | E | L | 0000 | LUZ1 | 1 | LND |
| F3740 |  | Preliminary Pipe Stress Calculation |  | 44d | 2008-05-20 A | 2008-07-18 A | F2730 FS+8d | 100% | F3740 | F3740 | 872 | 0F | 200 | 200 | 085 | F | 3A | LND | 1 | E | L | 0000 | LUZ1 | PI | LND |
| F3800 |  | Winterization package-Licensor | milestone | 0d | 2008-06-07 A | 2008-06-07 A | F3590 FF | 100% | F3800 | F3800 | 876 | 0F | 200 | 200 | 050 | F | 3A | PMT | 1 | E | L | 0000 | LUZ1 | PI | LND |
| F8980 |  | Tie-in Plan |  | 13d | 2008-07-14 A | 2008-07-30 A | F2510 FF | 100% | F8980 | F8980 | 876 | 0F | 200 |  |  | F | 3A | LND | 1 | E | L | 0000 | LUZ1 | E | PMT |
| F4470 |  | Underground Coordination Plan- Status D3 |  | 20d | 2008-08-01 A | 2008-08-28 A | F2590 FF | 100% | F4470 | F4470 | 876 | 0F | 200 | 200 | 050 | F | 3A | LND | 1 | E | L | 0000 | LUZ1 |  | LND |
| F3810 |  | Masterplotplan PDH/PP Plant confirmed PMT | milestone | 0d | 2008-09-11 A | 2008-09-11 A | F3600 FF | 100% | F3810 | F3810 | 876 | 0F | 200 | 200 | 050 | F | 3A | PMT | 1 | E | L | 0000 | LUZ1 | PI | LND |
| F3820 |  | UG Layout existing facilities (unsufficient) | milestone | 0d | 2008-10-31 A | 2008-10-31 A | F3600 | 100% | F3820 | F3820 | 876 | 0F | 200 | 200 | 050 | F | 3A | PMT | 1 | E | L | 0000 | LUZ1 | PI | LND |
| F4850 |  | Air Emission Plot Plan |  | 70d | 2008-12-01 A | 2009-03-13 A | AD2230 FF+5d, F2590 FF | 100% | F4850 | F4850 | 876 | 0F | 200 | 200 | 050 | F | 3A | LND | 1 | E | L | 0000 | LUZ1 | C | LND |

Notes:
- F1860: P3 Activity Log Info: 14.27
- F1870: P3 Activity Log Info: 14.27
- F1050: P3 Activity Log Info: 2.07
- F1300: P3 Activity Log Info: 4.11
- F1060: P3 Activity Log Info: 2.08
- F2730: P3 Activity Log Info: 14.16
- F1790: P3 Activity Log Info: 14.08
- F2590: P3 Activity Log Info: 14.10, 14.11
- F2510: P3 Activity Log Info: 14.07b
- F3740: P3 Activity Log Info: 14.17
- F3810: P3 Activity Log Info: commited delivery date 31DEC07

| ID | WBS | Activity | Type | Duration | Start | Finish | Predecessors | Complete | UDF_SAVE ACTID | UDF_SAVE ACT ID | Department | Constr. Area | PMT-Area | PMT-Schedule Org | PMT-Discipline | PMT-Phase | PMT-Stage | PMT-Respons. | Zeigen/n. Zeigen | WBS Phase | WBS Discipline | WBS Type of Work | WBS Objects | IMS | UPT | Pro Unit/DocCode |
| --- | --- | --- | --- | --- | --- | --- | --- | --- | --- | --- | --- | --- | --- | --- | --- | --- | --- | --- | --- | --- | --- | --- | --- | --- | --- | --- |
|  | 0000 | **0000 Generals - all CA's** |  |  | 2007-12-10 | 2009-06-30 |  |  |  |  |  |  |  |  |  |  |  |  |  |  |  |  |  |  |  |  |
|  | E | **E Electrical** |  |  | 2007-12-10 | 2009-06-30 |  |  |  |  |  |  |  |  |  |  |  |  |  |  |  |  |  |  |  |  |
| F1900 |  | General Electrical Design Specification & Standa |  | 121d | 2007-12-10 A | 2008-06-06 A | F1000 SS | 100% | F1900 | F1900 | 874 | 0F | 200 | 200 | 065 | F | 3A | LND | 1 | E | E | EE00 | 0000 | 1 | LND |  |
| F1890 |  | Electrical Design Basis |  | 82d | 2008-03-03 A | 2008-06-30 A | F3960 | 100% | F1890 | F1890 | 874 | 0F | 200 | 200 | 065 | F | 3A | LND | 1 | E | E | EE00 | 0000 | 1 | LND |  |
| F1910 |  | Key Single Line Diagrams |  | 76d | 2008-03-03 A | 2008-06-20 A | F1000 SS, F3960 | 100% | F1910 | F1910 | 874 | 0F | 200 | 200 | 065 | F | 3A | LND | 1 | E | E | EE00 | 0000 | 1 | LND |  |
| F8790 |  | Electrical Calculations |  | 52d | 2008-04-16 A | 2008-06-30 A | F1980 FF | 100% | F8790 | F8790 | 874 | 0F | 200 | 200 | 065 | F | 3A | LND | 1 | E | E | EE00 | 0000 | E | PMT |  |
| F1960 |  | Prel. electric cable distr. layoutdrwgs. |  | 45d | 2008-04-25 A | 2008-06-30 A | F1780 | 100% | F1960 | F1960 | 874 | 0F | 200 | 200 | 065 | F | 3A | LND | 1 | E | E | EE00 | 0000 | 1 | LND |  |
| F9040 |  | Preparation cost estimate acc. OBCE Proc. |  | 15d | 2008-05-27 A | 2008-06-16 A | F2760 | 100% | F9040 | F9040 | 874 | 0F | 200 | 200 | 065 | F | 3A | LND | 1 | E | E | EE00 | 0000 | E | PMT |  |
| F8930 |  | Input Electrical for Structural Steel Design | milestone | 0d | 2008-07-04 A | 2008-07-04 A | F1960 SS+23d | 100% | F8930 | F8930 | 874 | 0F | 200 | 200 | 065 | F | 3A | LND | 1 | E | E | EE00 | 0000 | E | PMT |  |
| F3960 |  | Standardization Electrical eng./design standards | milestone | 0d | 2008-10-01 A | 2008-10-01 A | F3950 FF | 100% | F3960 | F3960 | 874 | 0F | 200 | 200 | 065 | F | 3A | PMT | 1 | E | E | EE00 | 0000 | PI | LND |  |
| AD1780 |  | Change Responsibility Scope Electrical Eqpt. (SWG, etc.) | milestone | 0d | 2009-06-30 A | 2009-06-30 A | F9040 | 100% | AD1780 | AD1780 | 874 | 0F | 200 | 200 | 065 | F | 3A | PMT | 1 | E | E | EE00 | 0000 | INS | LND |  |
|  | 0A | **0A Advanced Detailengineering All Areas** |  |  | 2008-01-15 | 2011-04-25 |  |  |  |  |  |  |  |  |  |  |  |  |  |  |  |  |  |  |  |  |
|  | LUZ2 | **LUZ2 General ( )** |  |  | 2008-01-15 | 2011-03-11 |  |  |  |  |  |  |  |  |  |  |  |  |  |  |  |  |  |  |  |  |
|  | 0B | **0B General Activities** |  |  | 2008-06-02 | 2008-11-28 |  |  |  |  |  |  |  |  |  |  |  |  |  |  |  |  |  |  |  |  |
| F5010 |  | Advanced Detail Engineering (downstream) |  | 122d | 2008-06-02 A | 2008-11-21 A | F3130 SS, F1000 SS | 100% | F5010 | F5010 | 007 | 0A |  |  |  |  |  | LND |  | E | 0B | 0000 | LUZ2 | 1 | LND | 90 |
| F9260 |  | Advanced Detail Engineering (upstream) |  | 127d | 2008-06-02 A | 2008-11-28 A | F2550 FF, F2430, F9010 FF, F2030 FF, EJ46151005, F1970 FF, F5010 SS, F2770 FF, F2990 FF, F4770 FF | 100% | F9260 | F9260 | 007 | 0A |  |  |  |  |  | LND |  | E | 0B | 0000 | LUZ2 |  | LND | 91 |
|  | A | **A Project Management** |  |  | 2008-01-15 | 2008-12-15 |  |  |  |  |  |  |  |  |  |  |  |  |  |  |  |  |  |  |  |  |
| F1110 |  | Monthly Invoices |  | 233d | 2008-01-15 A | 2008-12-15 A | F1000 SS, F1030 FS-35d | 100% | F1110 | F1110 | 956 | 0A | 200 | 200 | 001 | F | 3A | LND | 1 | E | A | 0000 | LUZ2 | 1 | LND |  |
| F1020 |  | Project Progress Reports and Final Report |  | 217d | 2008-02-01 A | 2008-12-10 A | F1000 SS, F1010 FS-22d | 100% | F1020 | F1020 | 932 | 0A | 200 | 200 | 300 | F | 3A | LND | 1 | E | A | 0000 | LUZ2 | 1 | LND |  |
| F1070 |  | Project Cost and Productivity Reports |  | 217d | 2008-02-01 A | 2008-12-10 A | F1000 SS, F1030 FS-22d | 100% | F1070 | F1070 | 932 | 0A | 200 | 200 | 300 | F | 3A | LND | 1 | E | A | 0000 | LUZ2 | 1 | LND |  |
| F1120 |  | Monthly Reports |  | 217d | 2008-02-01 A | 2008-12-10 A | F1030 FS-22d, F1000 SS | 100% | F1120 | F1120 | 932 | 0A | 200 | 200 | 300 | F | 3A | LND | 1 | E | A | 0000 | LUZ2 | 1 | LND |  |
| AD2510 |  | Constructibility Study |  | 21d | 2008-06-02 A | 2008-06-30 A | F2760 | 100% | AD2510 | AD2510 | 934 | 0A | 200 | 200 |  | AD | 3A | LND | 1 | E | A | 0000 | LUZ2 | INS | LND |  |
| AD2600 |  | Inquieries other equipment & material |  | 127d | 2008-06-02 A | 2008-11-28 A | F2760 | 100% | AD2600 | AD2600 | 860 | 0A | 200 |  | 400 | AD | 3A | LND | 1 | E | A | 0000 | LUZ2 | INS | LND |  |
| AD2610 |  | Negotiations DCE |  | 112d | 2008-06-23 A | 2008-11-28 A | AD0140 FF+20d | 100% | AD2610 | AD2610 | 860 | 0A | 200 |  | 400 | AD | 3A | LND | 1 | E | A | 0000 | LUZ2 | INS | LND |  |
| AD2620 |  | Purchase Orders DCE |  | 104d | 2008-07-03 A | 2008-11-28 A | P3A04AD FF, P3A07D2 FF, P3A05D2 FF, P3U02D FF, P3A16D2 FF, P3A08D2 FF | 100% | AD2620 | AD2620 | 860 | 0A | 200 |  | 400 | AD | 3A | LND | 1 | E | A | 0000 | LUZ2 | INS | LND |  |

Notes:
- F1900: P3 Activity Log Info: 15.02
- F1890: P3 Activity Log Info: 15.01,15.14
- F1910: P3 Activity Log Info: 15.03
- F8790: P3 Activity Log Info: 15.09
- F1960: P3 Activity Log Info: 15.11
- F1110: P3 Activity Log Info: 2.14
- F1020: P3 Activity Log Info: 2.02
- F1070: P3 Activity Log Info: 2.09
- F1120: P3 Activity Log Info: 2.15

| ID | WBS | Activity | Type | Duration | Start | Finish | Predecessors | Complete | Resources | UDF_SAVE ACTID | UDF_SAVE ACT ID | Department | Constr. Area | Pro Unit/DocCode | Inquiry/Order No | PMT-Area | PMT-Schedule Org | PMT-Discipline | PMT-Phase | PMT-Respons. | Zeigen/n. Zeigen | WBS Phase | WBS Discipline | WBS Type of Work | WBS Objects | IMS | UPT | PMT-Stage | TB26 Ressource Budget |
| --- | --- | --- | --- | --- | --- | --- | --- | --- | --- | --- | --- | --- | --- | --- | --- | --- | --- | --- | --- | --- | --- | --- | --- | --- | --- | --- | --- | --- | --- |
|  | P | **P Process** |  |  | 2008-06-02 | 2010-09-30 |  |  |  |  |  |  |  |  |  |  |  |  |  |  |  |  |  |  |  |  |  |  |  |
| AD1200 |  | Participation on HAZOP |  | 20d | 2008-06-02 A | 2008-06-27 A | AD1300 FF | 100% |  | AD1200 | AD1200 | 924 | 0A | 91 | 999 | 200 | 200 | 025 | AD | LND | 1 | E | P | EF05 | LUZ2 | INS | LND |  |  |
| AD1210 |  | Incorpor. comments from HAZOP into PID Status E2 |  | 53d | 2008-06-04 A | 2008-08-15 A | AD1300 FF+10d | 100% |  | AD1210 | AD1210 | 924 | 0A | 91 | 999 | 200 | 200 | 025 | AD | LND | 1 | E | P | EF05 | LUZ2 | INS | LND |  |  |
| AD1220 |  | P&ID Status E2 Upstream Part |  | 43d | 2008-06-11 A | 2008-08-08 A | AD1270 FF+10d, AD1300 FF+15d | 100% |  | AD1220 | AD1220 | 924 | 0A | 91 | 999 | 200 | 200 | 025 | AD | LND | 1 | E | P | EF10 | LUZ2 | INS | LND |  |  |
| AD1010 |  | Review/Check of Vendor documents/drawings |  | 106d | 2008-06-30 A | 2008-11-27 A | AD0120 FF, AD0110 FF | 100% |  | AD1010 | AD1010 | 887 | 0A |  | 999 | 200 | 200 |  | AD | LND | 1 | E | P | EP20 | LUZ2 | INS | LND | 3A |  |
| AD1000 |  | Process engineering support for Departments |  | 102d | 2008-07-07 A | 2008-11-28 A | F8750 | 100% |  | AD1000 | AD1000 | 887 | 0A |  | 999 | 200 | 200 |  | AD | LND | 1 | E | P | EP20 | LUZ2 | INS | LND | 3A |  |
| AD1230 |  | Update Instruments, piping,valv lists/ Data Sheets |  | 50d | 2008-07-21 A | 2008-09-26 A | AD1220 FF+20d | 100% |  | AD1230 | AD1230 | 924 | 0A | 91 | 999 | 200 | 200 | 025 | AD | LND | 1 | E | P | EF20 | LUZ2 | INS | LND |  |  |
| AD1240 |  | Update extension control/DCs sequ./interlock des |  | 50d | 2008-07-21 A | 2008-09-26 A | AD1220 FF+20d | 100% |  | AD1240 | AD1240 | 924 | 0A | 91 | 999 | 200 | 200 | 025 | AD | LND | 1 | E | P | EF20 | LUZ2 | INS | LND |  |  |
| AD1250 |  | Hydraulical Calculations |  | 65d | 2008-07-21 A | 2008-10-20 A | AD1220 FF+20d | 100% |  | AD1250 | AD1250 | 924 | 0A | 91 | 999 | 200 | 200 | 025 | AD | LND | 1 | E | P | EF10 | LUZ2 | INS | LND |  |  |
| AD1030 |  | Updated Process & Block Flow Diagramm -F- |  | 57d | 2008-07-28 A | 2008-10-15 A | AD1220 | 100% |  | AD1030 | AD1030 | 887 | 0A |  | 999 | 200 | 200 |  | AD | LND | 1 | E | P | EP40 | LUZ2 | INS | LND | 3A |  |
| AD1040 |  | Update of Spec's-Utility/Feed&Prod Spec.-F- |  | 35d | 2008-07-28 A | 2008-09-12 A | AD1030 SS | 100% |  | AD1040 | AD1040 | 887 | 0A |  | 999 | 200 | 200 |  | AD | LND | 1 | E | P | EP30 | LUZ2 | INS | LND | 3A |  |
| AD1060 |  | Update of Process Description -F- |  | 23d | 2008-07-28 A | 2008-08-27 A | AD1030 FF+10d | 100% |  | AD1060 | AD1060 | 887 | 0A |  | 999 | 200 | 200 |  | AD | LND | 1 | E | P | EP20 | LUZ2 | INS | LND | 3A |  |
| AD1130 |  | Raw Material,catalyst&Chemicals summ F |  | 40d | 2008-07-28 A | 2008-09-19 A | AD1040 FF | 100% |  | AD1130 | AD1130 | 887 | 0A |  | 999 | 200 | 200 |  | AD | LND | 1 | E | P | EP30 | LUZ2 | INS | LND | 3A |  |
| AD1150 |  | Specification of Effluents F |  | 40d | 2008-07-28 A | 2008-09-19 A | AD1130 FF | 100% |  | AD1150 | AD1150 | 887 | 0A |  | 999 | 200 | 200 |  | AD | LND | 1 | E | P | EP30 | LUZ2 | INS | LND | 3A |  |
| AD1050 |  | Update of Utility Consumpt./Material Balance -F- |  | 62d | 2008-08-04 A | 2008-10-29 A | AD1060 FF+6d, AD1040 SS | 100% |  | AD1050 | AD1050 | 887 | 0A |  | 999 | 200 | 200 |  | AD | LND | 1 | E | P | EP20 | LUZ2 | INS | LND | 3A |  |
| AD1020 |  | Techn. Clarifications of quotations w/ vendors |  | 81d | 2008-08-05 A | 2008-11-28 A | AD0130 FF, AD1120 FF | 100% |  | AD1020 | AD1020 | 887 | 0A |  | 999 | 200 | 200 |  | AD | LND | 1 | E | P | EP20 | LUZ2 | INS | LND | 3A |  |
| AD1160 |  | Revise Process Description -F- |  | 57d | 2008-09-08 A | 2008-11-28 A | F2690 | 100% |  | AD1160 | AD1160 | 887 | 0A |  | 999 | 200 | 200 |  | AD | LND | 1 | E | P | EP20 | LUZ2 | INS | LND | 3A |  |
| AD1270 |  | P&ID Typicals for Instrumentation from PMT | milestone | 0d | 2008-09-13 A | 2008-09-13 A | F2760 | 100% |  | AD1270 | AD1270 | 924 | 0A |  | 999 | 200 | 200 | 025 | AD | PMT | 1 | E | P | EF20 | LUZ2 | INS | LND | 3A |  |
| EP30020 |  | Update of Spec's-Utility/Feed&Prod Spec.-H- |  | 129d | 2010-03-30 A | 2010-09-30 A | IMS-E-000010 FF, IMS-E-000020, F4460 FF+20d | 100% | CP [64 h] | EP30020 | EP30020 | 887 | 0A |  | 999 | 200 | 200 |  | AD | LND | 1 | E | P | EP30 | LUZ2 | 1 | LND | 3A | 64,00 |
| EP30030 |  | Heat & Material Balance -H- |  | 57d | 2010-06-28 A | 2010-09-14 A | EP20050, F4460 FF+4d | 100% | CP [64 h] | EP30030 | EP30030 | 887 | 0A |  | 999 | 200 | 200 |  | AD | LND | 1 | E | P | EP30 | LUZ2 | 1 | LND | 3A | 64,00 |
|  | L | **L Plant Design** |  |  | 2008-10-01 | 2008-11-28 |  |  |  |  |  |  |  |  |  |  |  |  |  |  |  |  |  |  |  |  |  |  |  |
| RF1000 |  | Re-engineering and value awreness |  | 40d | 2008-10-01 A | 2008-11-28 A | F2765 | 100% |  | RF1000 | RF1000 | 876 | 0A |  |  | 200 | 200 | 070 | AD | LND | 1 | E | L | 0000 | LUZ2 | S | LND | 3A |  |
|  | C | **C Civil** |  |  | 2008-06-02 | 2011-01-20 |  |  |  |  |  |  |  |  |  |  |  |  |  |  |  |  |  |  |  |  |  |  |  |
| F4690 |  | CA00 General - BOQ Civil Works PP-Plant |  | 20d | 2008-06-02 A | 2008-06-27 A | F3470 | 100% |  | F4690 | F4690 | 87A | 0A |  |  | 200 | 200 |  | AD | LND |  | E | C | EC00 | LUZ2 |  | LND |  |  |
| AD1910 |  | Inquiry Civil Detail Engineering |  | 116d | 2008-06-17 A | 2008-11-28 A | F8920 | 100% |  | AD1910 | AD1910 | 87A | 0A |  |  | 200 | 200 |  | AD | LND | 1 | E | C | EC00 | LUZ2 | INS | LND | 3A |  |
| AD1920 |  | Prep. Foundation Data Sheets 1st lot (DCE) |  | 92d | 2008-07-21 A | 2008-11-28 A | AD1010 FF, AD0120 FF | 100% |  | AD1920 | AD1920 | 87A | 0A |  |  | 200 | 200 |  | AD | LND | 1 | E | C | EC00 | LUZ2 | INS | LND | 3A |  |
| AD1900 |  | Completion of 3D- model for 30% DRV |  | 77d | 2008-08-11 A | 2008-11-28 A | AD2230 SF | 100% |  | AD1900 | AD1900 | 87A | 0A |  |  | 200 | 200 |  | AD | LND | 1 | E | C | EC00 | LUZ2 | INS | LND | 3A |  |
| RF1040 |  | Re-engineering and Value Awareness |  | 40d | 2008-10-01 A | 2008-11-28 A | F4250 | 100% |  | RF1040 | RF1040 | 87A | 0A |  |  | 200 | 200 | 070 | AD | LND | 1 | E | C | EC00 | LUZ2 | S | LND | 3A |  |
| AD1930 |  | Incorporation results 30% DRV part1 ->3D model |  | 38d | 2008-10-06 A | 2008-11-28 A | F3060 | 100% |  | AD1930 | AD1930 | 87A | 0A |  |  | 200 | 200 |  | AD | LND | 1 | E | C | EC00 | LUZ2 | INS | LND | 3A |  |
| EC000040 |  | Input for OBCE, Issue of BOQ's |  | 20d | 2009-01-05 A | 2009-01-30 A | F8920 | 100% |  | EC000040 | EC000040 | 87A | 0A |  |  | 200 | 200 |  | AD | LND | 1 | E | C | EC00 | LUZ2 | 3 | LND | 3A |  |
| F4880 |  | Soil investigation Report to deliver by PMT | milestone | 0d | 2009-01-10 A | 2009-01-10 A | E0203130, E0203120, E0203110, E0203140 | 100% |  | F4880 | F4880 | 87A | 0A |  |  | 200 | 200 | 010 | AD | PMT | 1 | E | C | EC00 | LUZ2 | C | LND | 3A |  |
| EC000165 |  | Participation 60% DSRV -downstream- | level of effort | 7d | 2009-10-19 A | 2009-10-27 A | F4035 SS, F4035 FF | 100% |  | EC000165 | EC000165 | 87A | 0A |  |  | 200 | 200 |  | AD | LND | 1 | E | C | EC00 | LUZ2 | de | LND | 3A |  |
| EC000160 |  | Participation 60% DSRV -upstream- 11/12/13/51/55-56 | level of effort | 12d | 2009-11-02 A | 2009-11-17 A | F4030 FF, F4030 SS, EC000165 | 100% |  | EC000160 | EC000160 | 87A | 0A |  |  | 200 | 200 |  | AD | LND | 1 | E | C | EC00 | LUZ2 | de | LND | 3A |  |
| EC000170 |  | Participation 60% DSRV -upstream- 15/16/17/52,54 | level of effort | 15d | 2010-03-01 A | 2010-03-19 A | EC000160, F4040 SS, F4040 FF | 100% |  | EC000170 | EC000170 | 87A | 0A |  |  | 200 | 200 |  | AD | LND | 1 | E | C | EC00 | LUZ2 | de | LND | 3A |  |
| EC000190 |  | Participation 90% DSRV -downstream- | level of effort | 10d | 2010-04-26 A | 2010-05-07 A | F9250 FF, F9250 SS, EC000170 | 100% |  | EC000190 | EC000190 | 87A | 0A |  |  | 200 | 200 |  | AD | LND | 1 | E | C | EC00 | LUZ2 | de | LND | 3A |  |
| EC000195 |  | Participation 90% DSRV -upstream- 11/12/13/51-56 | level of effort | 15d | 2010-06-21 A | 2010-07-09 A | EC000190, F4460 FF, F4460 SS | 100% |  | EC000195 | EC000195 | 87A | 0A |  |  | 200 | 200 |  | AD | LND | 1 | E | C | EC00 | LUZ2 | de | LND | 3A |  |
| EC000200 |  | Participation 90% DSRV -upstream- 17 | level of effort | 10d | 2010-09-06 A | 2010-09-17 A | EC000195, F4462 SS, F4462 FF | 100% |  | EC000200 | EC000200 | 87A | 0A |  |  | 200 | 200 |  | AD | LND | 1 | E | C | EC00 | LUZ2 | de | LND | 3A |  |
| EC000175 |  | Participation 60% DSRV -upstream- 10/14/53 | level of effort | 86d | 2010-09-20 A | 2011-01-20 A | EC000200 FF, F4048 FF, F4045 SS, F4045 FF, F4048 SS | 100% |  | EC000175 | EC000175 | 87A | 0A |  |  | 200 | 200 |  | AD | LND | 1 | E | C | EC00 | LUZ2 | de | LND | 3A |  |

| ID | WBS | Activity | Type | Duration | Start | Finish | Predecessors | Complete | Resources | UDF_SAVE ACTID | UDF_SAVE ACT ID | Department | Constr. Area | PMT-Area | PMT-Schedule Org | PMT-Discipline | PMT-Phase | PMT-Stage | PMT-Respons. | Zeigen/n. Zeigen | WBS Phase | WBS Discipline | WBS Type of Work | WBS Objects | IMS | UPT | TB26 Ressource Budget |
| --- | --- | --- | --- | --- | --- | --- | --- | --- | --- | --- | --- | --- | --- | --- | --- | --- | --- | --- | --- | --- | --- | --- | --- | --- | --- | --- | --- |
|  | N | **N Structural Steel** |  |  | 2008-09-04 | 2011-03-11 |  |  |  |  |  |  |  |  |  |  |  |  |  |  |  |  |  |  |  |  |  |
| AD1400 |  | Struc Steel -Completion of 3D- model for 30% DRV |  | 59d | 2008-09-04 A | 2008-11-28 A | M3T110 FF | 100% |  | AD1400 | AD1400 | 87B | 0A | 200 | 200 | 015 | AD | 3A | LND | 1 | E | N | 0000 | LUZ2 | INS | LND |  |
| RF1030 |  | Re-engineering and Value Awareness |  | 20d | 2008-10-01 A | 2008-10-29 A | F4260 | 100% |  | RF1030 | RF1030 | 87B | 0A | 200 | 200 | 070 | AD | 3A | LND | 1 | E | N | EN00 | LUZ2 | S | LND |  |
| AD1410 |  | Struc Steel - Results 30% DRV part1->3D model |  | 6d | 2008-11-04 A | 2008-11-11 A | F3060, F1570 | 100% |  | AD1410 | AD1410 | 87B | 0A | 200 | 200 | 015 | AD | 3A | LND | 1 | E | N | 0000 | LUZ2 | INS | LND |  |
| AD1420 |  | Struc Steel - Results 30% DRV part2->3D model |  | 4d | 2008-12-22 A | 2008-12-30 A | AD2230, AD1410 | 100% |  | AD1420 | AD1420 | 87B | 0A | 200 | 200 | 015 | AD | 3A | LND | 1 | E | N | 0000 | LUZ2 | INS | LND |  |
| EN000040 |  | Input for OBCE, Issue of BOQ's |  | 20d | 2009-01-05 A | 2009-01-30 A | F2440 | 100% |  | EN000040 | EN000040 | 87B | 0A | 200 | 200 | 015 | AD | 3A | LND | 1 | E | N | 0000 | LUZ2 | I | LND |  |
| EN250000 |  | General Coordination works LKCA / supervision LEI |  | 401d | 2009-08-12 A | 2011-03-11 A | EN265503 FF+20d, EN671707 FF+20d, EN265601 FF+20d, EN671705 FF+20d, EN671708 FF+20d, EN265201 FF+20d, EN671704 FF+20d | 100% | TKB-S [3344 h] | EN250000 | EN250000 | 87B | 0A | 200 | 200 | 015 | AD | 3A | LND | 1 | E | N | 0000 | LUZ2 | de | LND | 3344,00 |
| EN250020 |  | Hoist works LKCA |  | 345d | 2009-10-16 A | 2011-02-28 A | F4030 FF+20d | 100% | TKB-S [1600 h] | EN250020 | EN250020 | 87B | 0A | 200 | 200 | 015 | AD | 3A | LND | 1 | E | N | 0000 | LUZ2 | de | LND | 1600,00 |
| EN000165 |  | Participation 60% DSRV -downstream- | level of effort | 7d | 2009-10-19 A | 2009-10-27 A | F4035 SS, F4035 FF | 100% |  | EN000165 | EN000165 | 87B | 0A | 200 | 200 | 015 | AD | 3A | LND | 1 | E | N | 0000 | LUZ2 | de | LND |  |
| EN250010 |  | General Coordination works LEI |  | 348d | 2009-10-26 A | 2011-03-11 A | EN265201 FF+20d, EN671708 FF+20d, EN671705 FF+20d, EN671707 FF+20d, EN265601 FF+20d, EN265503 FF+20d, EN671704 FF+20d | 100% | TKB-S [5360 h] | EN250010 | EN250010 | 87B | 0A | 200 | 200 | 015 | AD | 3A | LEI | 1 | E | N | 0000 | LUZ2 | de | LND | 5360,00 |
| EN000160 |  | Participation 60% DSRV -upstream- 11/12/13/51/55-56 | level of effort | 12d | 2009-11-02 A | 2009-11-17 A | F4030 FF, F4030 SS | 100% |  | EN000160 | EN000160 | 87B | 0A | 200 | 200 | 015 | AD | 3A | LND | 1 | E | N | 0000 | LUZ2 | de | LND |  |
| EN250030 |  | General Coordination subcontractors |  | 314d | 2009-12-01 A | 2011-02-28 A | DE1000 | 100% | TKB-S [2880 h] | EN250030 | EN250030 | 87B | 0A | 200 | 200 | 015 | AD | 3A | LEI | 1 | E | N | 0000 | LUZ2 | de | LND | 2880,00 |
| A1010080 |  | Hoist works LEI |  | 275d | 2010-01-29 A | 2011-02-28 A | F4030 FF+20d, EN250020 SS+70d | 100% | TKB-S [1600 h] | A1010080 | A1010080 | 87B | 0A | 200 | 200 | 015 | AD | 3A | LEI | 1 | E | N | 0000 | LUZ2 | de | LND | 1600,00 |
| EN000170 |  | Participation 60% DSRV -upstream- 15/16/17/52,54 | level of effort | 15d | 2010-03-01 A | 2010-03-19 A | EN000160, F4040 FF, F4040 SS | 100% |  | EN000170 | EN000170 | 87B | 0A | 200 | 200 | 015 | AD | 3A | LND | 1 | E | N | 0000 | LUZ2 | de | LND |  |
| EN000190 |  | Participation 90% DSRV -downstream- | level of effort | 10d | 2010-04-26 A | 2010-05-07 A | EN000170, F9250 SS, F9250 FF | 100% |  | EN000190 | EN000190 | 87B | 0A | 200 | 200 | 015 | AD | 3A | LND | 1 | E | N | 0000 | LUZ2 | de | LND |  |
| EN000195 |  | Participation 90% DSRV -upstream- 11/12/13/51-56 | level of effort | 15d | 2010-06-21 A | 2010-07-09 A | F4460 SS, EN000190, F4460 FF | 100% |  | EN000195 | EN000195 | 87B | 0A | 200 | 200 | 015 | AD | 3A | LND | 1 | E | N | 0000 | LUZ2 | de | LND |  |
| EN260000 |  | Revision of Layout dwgs for KM dwgs |  | 90d | 2010-07-01 A | 2010-11-03 A | F4460 FF, EN265101 | 100% |  | EN260000 | EN260000 | 87B | 0A | 200 | 200 | 015 | AD | 3A | LND | 1 | E | N | 0000 | LUZ2 | de | LND |  |
| EN000200 |  | Participation 90% DSRV -upstream- 17 | level of effort | 10d | 2010-09-06 A | 2010-09-17 A | F4462 FF, EN000195, F4462 SS | 100% |  | EN000200 | EN000200 | 87B | 0A | 200 | 200 | 015 | AD | 3A | LND | 1 | E | N | 0000 | LUZ2 | de | LND |  |
| EN000175 |  | Participation 60% DSRV -upstream- 10/14/53 | level of effort | 86d | 2010-09-20 A | 2011-01-20 A | F4048 SS, F4048 FF, F4045 FF, F4045 SS | 100% |  | EN000175 | EN000175 | 87B | 0A | 200 | 200 | 015 | AD | 3A | LND | 1 | E | N | 0000 | LUZ2 | de | LND |  |
|  | H | **H HVAC** |  |  | 2008-08-25 | 2011-01-20 |  |  |  |  |  |  |  |  |  |  |  |  |  |  |  |  |  |  |  |  |  |
| AD1500 |  | HVAC - Preparation/Participation 30% DRV part1 |  | 67d | 2008-08-25 A | 2008-11-28 A | M3T110 FF | 100% |  | AD1500 | AD1500 | 87C | 0A | 200 | 200 | 035 | AD | 3A | LND | 1 | E | H | 0000 | LUZ2 | INS | LND |  |
| RF1020 |  | Re-engineering and Value Awareness |  | 40d | 2008-10-01 A | 2008-11-28 A | F4250 | 100% |  | RF1020 | RF1020 | 87C | 0A | 200 | 200 | 070 | AD | 3A | LND | 1 | E | H | 0000 | LUZ2 | S | LND |  |
| AD1510 |  | HVAC - Incorporate results from 30% DRV part1 |  | 17d | 2008-11-05 A | 2008-11-28 A | AD1500 FF | 100% |  | AD1510 | AD1510 | 87C | 0A | 200 | 200 | 035 | AD | 3A | LND | 1 | E | H | 0000 | LUZ2 | INS | LND |  |
| EH000120 |  | Participation 30% DSRV Part 2 -up-/downstream- | level of effort | 5d | 2008-12-15 A | 2008-12-19 A | AD2230 SS, AD1510 | 100% |  | EH000120 | EH000120 | 87C | 0A | 200 | 200 | 035 | AD | 3A | LND | 1 | E | H | 0000 | LUZ2 | 1 | LND |  |
| EH000040 |  | Input for OBCE, Issue of BOQ's |  | 20d | 2009-01-05 A | 2009-01-30 A | F2290 | 100% |  | EH000040 | EH000040 | 87C | 0A | 200 | 200 | 035 | AD | 3A | LND | 1 | E | H | 0000 | LUZ2 | 1 | LND |  |
| E3H150 |  | Douments VNP TEOC approveable/available (final) | milestone | 0d | 2009-10-05 A | 2009-10-05 A | P3C00E FF, E3C150 FF | 100% |  | E3H150 | E3H150 | 87C | 0A | 200 |  |  | AD |  | PMT | C1 | E | H | EC00 | LUZ2 | OTH | LND |  |
| EH000165 |  | Participation 60% DSRV -downstream- | level of effort | 7d | 2009-10-19 A | 2009-10-27 A | F4035 FF, F4035 SS | 100% |  | EH000165 | EH000165 | 87C | 0A | 200 | 200 | 035 | AD | 3A | LND | 1 | E | H | 0000 | LUZ2 | OTH | LND |  |
| EH000160 |  | Participation 60% DSRV -upstream- 11/12/13/51/55-56 | level of effort | 12d | 2009-11-02 A | 2009-11-17 A | EH000165, F4030 SS, F4030 FF | 100% |  | EH000160 | EH000160 | 87C | 0A | 200 | 200 | 035 | AD | 3A | LND | 1 | E | H | 0000 | LUZ2 | 2 | LND |  |
| EH000170 |  | Participation 60% DSRV -upstream- 15/16/17/52,54 | level of effort | 15d | 2010-03-01 A | 2010-03-19 A | F4040 FF, EH000160, F4040 SS | 100% |  | EH000170 | EH000170 | 87C | 0A | 200 | 200 | 035 | AD | 3A | LND | 1 | E | H | 0000 | LUZ2 | 2 | LND |  |
| EH000190 |  | Participation 90% DSRV -downstream- | level of effort | 10d | 2010-04-26 A | 2010-05-07 A | EH000170, F9250 SS, F9250 FF | 100% |  | EH000190 | EH000190 | 87C | 0A | 200 | 200 | 035 | AD | 3A | LND | 1 | E | H | 0000 | LUZ2 | 3 | LND |  |
| EH000195 |  | Participation 90% DSRV -upstream- 11/12/13/51-56 | level of effort | 15d | 2010-06-21 A | 2010-07-09 A | EH000190, F4460 FF, F4460 SS | 100% |  | EH000195 | EH000195 | 87C | 0A | 200 | 200 | 035 | AD | 3A | LND | 1 | E | H | 0000 | LUZ2 | OTH | LND |  |
| EH000200 |  | Participation 90% DSRV -upstream- 17 | level of effort | 10d | 2010-09-06 A | 2010-09-17 A | F4462 SS, F4462 FF, EH000195 | 100% |  | EH000200 | EH000200 | 87C | 0A | 200 | 200 | 035 | AD | 3A | LND | 1 | E | H | 0000 | LUZ2 | OTH | LND |  |
| EH000175 |  | Participation 60% DSRV -upstream- 10/14/53 | level of effort | 86d | 2010-09-20 A | 2011-01-20 A | F4045 FF, EH000200, F4048 FF, F4048 SS, F4045 SS | 100% |  | EH000175 | EH000175 | 87C | 0A | 200 | 200 | 035 | AD | 3A | LND | 1 | E | H | 0000 | LUZ2 | 2 | LND |  |

| ID | WBS | Activity | Type | Duration | Start | Finish | Predecessors | Complete | Resources | UDF_SAVE ACTID | UDF_SAVE ACT ID | Department | Type of Work | Constr. Area | Inquiry/Order No | PMT-Area | PMT-Schedule Org | PMT-Discipline | PMT-Phase | PMT-Doc. Type | PMT-Respons. | Zeigen/n. Zeigen | WBS Phase | WBS Discipline | WBS Type of Work | WBS Objects | IMS | UPT | Pro Unit/DocCode | PMT-Stage | TB26 Ressource Budget |
| --- | --- | --- | --- | --- | --- | --- | --- | --- | --- | --- | --- | --- | --- | --- | --- | --- | --- | --- | --- | --- | --- | --- | --- | --- | --- | --- | --- | --- | --- | --- | --- |
|  | U | **U Package Units** |  |  | 2008-03-17 | 2010-07-26 |  |  |  |  |  |  |  |  |  |  |  |  |  |  |  |  |  |  |  |  |  |  |  |  |  |
| E3U1510 |  | PU15 Reactor Seal Oil Pack - Inquiry Spec. |  | 8d | 2008-03-17 A | 2008-03-28 A | F1670 SS+15d | 100% |  | E3U1510 | E3U1510 | 869 | PU15 | 0A | 2DC8910 | 200 | 200 | 055 | AD | DEV | LND | 0 | E | U | EU93 | LUZ2 | 2 | LND |  |  |  |
| E3U1010 |  | PU10 Convey. Syst. - Basic Engin. Phase 2 |  | 20d | 2008-04-28 A | 2008-05-27 A | F10420 | 100% |  | E3U1010 | E3U1010 | 869 | PU10 | 0A | 2DC8990 | 200 | 200 | 055 | AD | DEV | LND | C2 | E | U | EU13 | LUZ2 | 3 | LND | DC |  |  |
| E3U1020 |  | PU10 Convey. Syst. - Techn. Eval./PO Spec. |  | 45d | 2008-07-14 A | 2008-09-12 A | P3U10B FS+10d, E3U1010 | 100% |  | E3U1020 | E3U1020 | 869 | PU10 | 0A | 2DC8990 | 200 | 200 | 055 | AD |  | LND | C2 | E | U | EU14 | LUZ2 | 3 | LND | DC |  |  |
| E3U1030 |  | PU10 Convey. Syst. - Techn. Eval./Bid Tab Final | milestone | 0d | 2008-08-08 A | 2008-08-08 A | F10460, E3U1020 FF-5d | 100% |  | E3U1030 | E3U1030 | 869 | PU10 | 0A | 2DC8990 | 200 | 200 | 055 | AD |  | LND | C2 | E | U | EU14 | LUZ2 | 3 | LND | DC |  |  |
| AD5000 |  | Product Handling (Advanced Detail ) |  | 72d | 2008-08-18 A | 2008-11-28 A | F3720 | 100% |  | AD5000 | AD5000 | N |  | 0A |  | 200 | 200 | 025 | AD |  | LND | 1 | E | U | 0000 | LUZ2 | INS | LND |  | 3A |  |
| E3U0510 |  | PU05 Big Bag L. Station - Inquiry Spec. |  | 7d | 2008-08-21 A | 2008-08-29 A | F1670 SS+15d | 100% |  | E3U0510 | E3U0510 | 869 | PU05 | 0A | 2DC9640 | 200 | 200 | 055 | AD | DEV | LND | 0 | E | U | EU93 | LUZ2 | 1 | LND |  |  |  |
| E3U1520 |  | PU15 Reactor Seal Oil Pac - Techn. Eval./PO Spec |  | 210d | 2008-10-09 A | 2009-08-14 A | P3U15B FS+130d | 100% |  | E3U1520 | E3U1520 | 869 | PU15 | 0A | 2DC8910 | 200 | 200 | 055 | AD |  | LND | 0 | E | U | EU94 | LUZ2 | 2 | LND |  |  |  |
| E3U0520 |  | PU05 Big Bag L. Station - Techn. Eval./PO Spec |  | 441d | 2008-10-17 A | 2010-07-26 A | P3U05B FS+25d, HEB20 FF | 100% | TAA [800 h] | E3U0520 | E3U0520 | 869 | PU05 | 0A | 2DC9640 | 200 | 200 | 055 | AD |  | LND | 0 | E | U | EU94 | LUZ2 | 2 | LND |  |  | 800,00 |
|  | B | **B Mechanical - Stationary Equipment** |  |  | 2008-04-08 | 2009-02-20 |  |  |  |  |  |  |  |  |  |  |  |  |  |  |  |  |  |  |  |  |  |  |  |  |  |
| F4580 |  | 1st Review Vendor Drawings summary | level of effort | 219d | 2008-04-08 A | 2009-02-20 A | E3A0440 SS, E3A04A40 SS, E3M0640 SS, E3U0240 SS, E3A0740 SS, E3M0540 SS, E3M0140 SS, E3M1140 SS, E3ALL240 SS, E3M0440 SS, E3U0240 FF, E3A0540 SS, E3ALL140 SS, E3M0240 SS, E3A0840 SS, E3A1640 SS, E3M0340 SS, E3M0540 FF, E3M1140 FF | 100% |  | F4580 | F4580 | 869 |  | 0A | PP | 200 |  | 055 | AD |  | LND | C2 | E | B | 0000 | LUZ2 |  | LND |  | 3A |  |
| E3A1310 |  | A13 Scales - Inquiry Spec. |  | 9d | 2008-05-05 A | 2008-05-16 A | F1670 SS+50d | 100% |  | E3A1310 | E3A1310 | 869 | A13 | 0A | 2DC9060 | 200 | 200 | 055 | E | DEV | LND | 0 | E | B | EB93 | LUZ2 | 3 | LND |  |  |  |
| AD0100 |  | Preparation P.O. Equipment Design Critical Items |  | 133d | 2008-05-23 A | 2008-11-28 A | P3A05D2 FF, P3A08D2 FF, P3A04AD FF, P3A16D2 FF, P3A07D2 FF, P3U02D FF | 100% |  | AD0100 | AD0100 | 869 |  | 0A |  | 200 | 200 | 055 | AD |  | LND | 1 | E | B | 0000 | LUZ2 | INS | LND |  | 3A |  |
| AD0130 |  | Technical Clarification DCE |  | 99d | 2008-06-02 A | 2008-10-17 A | F5060 FF+10d, F5760 FF+10d, F8010 FF+10d, F6960 FF+10d, F10040 FF+10d, F5560 FF+10d, F8410 FF+10d, F5260 FF+10d | 100% |  | AD0130 | AD0130 | 869 |  | 0A |  | 200 | 200 | 055 | AD |  | LND | 1 | E | B | 0000 | LUZ2 | INS | LND |  | 3A |  |
| AD0150 |  | Final bid Tabulation DCE |  | 108d | 2008-06-02 A | 2008-10-30 A | F8190 FF, F5240 FF, F8590 FF, F5940 FF, F10090 FF, F5740 FF, F5440 FF, F7140 FF | 100% |  | AD0150 | AD0150 | 869 |  | 0A |  | 200 | 200 | 055 | AD |  | LND | 1 | E | B | 0000 | LUZ2 | INS | LND |  | 3A |  |
| AD0140 |  | Vendor Negotiations DCE |  | 90d | 2008-06-11 A | 2008-10-15 A | P3ALL4C FF, P3A04C FF, P3A05C FF, F5060 FF, P3A04AC FF, P3U02C FF, P3A16C FF, P3A08C FF | 100% |  | AD0140 | AD0140 | 869 |  | 0A |  | 200 | 200 | 055 | AD |  | LND | 1 | E | B | 0000 | LUZ2 | INS | LND |  | 3A |  |
| AD0160 |  | Inquiries big vessels |  | 28d | 2008-06-11 A | 2008-07-18 A | F2420 | 100% |  | AD0160 | AD0160 | 869 |  | 0A |  | 200 | 200 | 055 | AD |  | LND | 1 | E | B | 0000 | LUZ2 | INS | LND |  | 3A |  |
| AD0110 |  | Review Vendor Documents LLI |  | 118d | 2008-06-12 A | 2008-11-27 A | E3ALL140 FF, E3ALL240 FF, E3ALL440 FF, E3U0240 FF | 100% |  | AD0110 | AD0110 | 869 |  | 0A |  | 200 | 200 | 055 | AD |  | LND | 1 | E | B | 0000 | LUZ2 | INS | LND |  | 3A |  |
| AD0170 |  | Inquiries other equipment |  | 40d | 2008-06-17 A | 2008-08-11 A | AD0160 SS | 100% |  | AD0170 | AD0170 | 869 |  | 0A |  | 200 | 200 | 055 | AD |  | LND | 1 | E | B | 0000 | LUZ2 | INS | LND |  | 3A |  |
| AD0180 |  | Technical Clarification other equipment |  | 110d | 2008-06-25 A | 2008-11-28 A | AD0170 FF+32d | 100% |  | AD0180 | AD0180 | 869 |  | 0A |  | 200 | 200 | 055 | AD |  | LND | 1 | E | B | 0000 | LUZ2 | INS | LND |  | 3A |  |
| AD0120 |  | 1st Review Vendor Documents DCE |  | 94d | 2008-07-15 A | 2008-11-26 A | E3U1040 FF, E3A1640 FF, E3A0540 FF, E3A04A40 SF, E3A0740 FF, E3U0240 FF, E3A0840 FF | 100% |  | AD0120 | AD0120 | 869 |  | 0A |  | 200 | 200 | 055 | AD |  | LND | 1 | E | B | 0000 | LUZ2 | INS | LND |  | 3A |  |
|  | E | **E Electrical** |  |  | 2008-07-14 | 2009-02-27 |  |  |  |  |  |  |  |  |  |  |  |  |  |  |  |  |  |  |  |  |  |  |  |  |  |
| AD1750 |  | Cable tray layout 3D-Model AD |  | 97d | 2008-07-14 A | 2008-11-28 A | F2510 FF+20d | 100% |  | AD1750 | AD1750 | 874 |  | 0A |  | 200 | 200 | 065 | AD |  | LND | 1 | E | E | EE46 | LUZ2 | INS | LND |  | 3A |  |
| EE460000 |  | Cable tray layout 3D-Model DE inp. f. LEI |  | 60d | 2008-12-01 A | 2009-02-27 A | AD1750 | 100% |  | EE460000 | EE460000 | 874 |  | 0A |  | 200 | 200 | 065 | AD |  | LND | 1 | E | E | EE46 | LUZ2 | E | LND |  | 3A |  |

| ID | WBS | Activity | Type | Duration | Start | Finish | Predecessors | Complete | Resources | UDF_SAVE ACTID | UDF_SAVE ACT ID | Department | Constr. Area | Pro Unit/DocCode | PMT-Area | PMT-Schedule Org | PMT-Discipline | PMT-Phase | PMT-Stage | PMT-Respons. | Zeigen/n. Zeigen | WBS Phase | WBS Discipline | WBS Type of Work | WBS Objects | IMS | UPT | Type of Work | Inquiry/Order No | TB26 Ressource Budget |
| --- | --- | --- | --- | --- | --- | --- | --- | --- | --- | --- | --- | --- | --- | --- | --- | --- | --- | --- | --- | --- | --- | --- | --- | --- | --- | --- | --- | --- | --- | --- |
|  | J | **J Instrumentation** |  |  | 2008-06-02 | 2010-08-18 |  |  |  |  |  |  |  |  |  |  |  |  |  |  |  |  |  |  |  |  |  |  |  |  |
| AD1940 |  | Developm. cable tray layout |  | 108d | 2008-06-02 A | 2008-10-30 A | F2760 | 100% |  | AD1940 | AD1940 | 86A | 0A | 999 | 200 | 200 | 070 | AD | 3A | LND | 1 | E | J | 0000 | LUZ2 | INS | LND |  |  |  |
| AD1840 |  | Developm. of standard. of control conc. f. PU's |  | 68d | 2008-06-19 A | 2008-09-22 A | F2010 FF | 100% |  | AD1840 | AD1840 | 86A | 0A | 999 | 200 | 200 | 070 | AD | 3A | LND | 1 | E | J | 0000 | LUZ2 | INS | LND |  |  |  |
| AD1880 |  | Technical support for PU's |  | 66d | 2008-06-20 A | 2008-09-19 A | AD1010 FF-10d | 100% |  | AD1880 | AD1880 | 86A | 0A | 999 | 200 | 200 | 070 | AD | 3A | LND | 1 | E | J | 0000 | LUZ2 | INS | LND |  |  |  |
| AD1800 |  | Verification of PMT-FEED-Documents |  | 62d | 2008-07-07 A | 2008-09-30 A | AD1890 | 100% |  | AD1800 | AD1800 | 86A | 0A | 999 | 200 | 200 | 070 | AD | 3A | LND | 1 | E | J | 0000 | LUZ2 | INS | LND |  |  |  |
| AD1850 |  | Inqu. field instr. devices+Valves (inliner) |  | 82d | 2008-07-07 A | 2008-10-29 A | E3J0310 FF, E3J04A10 FF, E3J04I10 FF | 100% |  | AD1850 | AD1850 | 86A | 0A | 999 | 200 | 200 | 070 | AD | 3A | LND | 1 | E | J | 0000 | LUZ2 | INS | LND |  |  |  |
| AD1820 |  | Specification of Safety Instr.Syst. SIS |  | 86d | 2008-07-14 A | 2008-11-12 A | AD1240 FF+8d | 100% |  | AD1820 | AD1820 | 86A | 0A | 999 | 200 | 200 | 070 | AD | 3A | LND | 1 | E | J | 0000 | LUZ2 | INS | LND |  |  |  |
| AD1830 |  | Specification of Machine Monitoring System |  | 53d | 2008-07-16 A | 2008-09-26 A | F2760 | 100% |  | AD1830 | AD1830 | 86A | 0A | 999 | 200 | 200 | 070 | AD | 3A | LND | 1 | E | J | 0000 | LUZ2 | INS | LND |  |  |  |
| AD1860 |  | Bid evaluation for Valves+Field Instrument Devic |  | 85d | 2008-07-16 A | 2008-11-13 A | AD1850 FF+10d, E3J0230 FF-10d, E3J0130 FF-11d, E3J01A30 FF-12d, E3J02C30 FF | 100% |  | AD1860 | AD1860 | 86A | 0A | 999 | 200 | 200 | 070 | AD | 3A | LND | 1 | E | J | 0000 | LUZ2 | INS | LND |  |  |  |
| AD1810 |  | Developm. of architect. control/automation conc. |  | 68d | 2008-07-28 A | 2008-10-30 A | AD1220 | 100% |  | AD1810 | AD1810 | 86A | 0A | 999 | 200 | 200 | 070 | AD | 3A | LND | 1 | E | J | 0000 | LUZ2 | INS | LND |  |  |  |
| AD1870 |  | Preparation P.O. for (PDS-)Valves |  | 78d | 2008-08-01 A | 2008-11-21 A | AD1220 FF+15d | 100% |  | AD1870 | AD1870 | 86A | 0A | 999 | 200 | 200 | 070 | AD | 3A | LND | 1 | E | J | 0000 | LUZ2 | INS | LND |  |  |  |
| E3J0350 |  | J03 Nuclear Level Meas. - Vendor dwgs approved | milestone | 0d | 2008-08-01 A | 2008-08-01 A | P3J03D1 FF+35d | 100% |  | E3J0350 | E3J0350 | 86B | 0A | 999 | 200 | 200 |  | E |  | LND | 0 | E | J | EJ35 | LUZ2 | PI | LND | J03 | 2JD7540 |  |
| E3J01A20 |  | J01A Ball Valves - Techn. Eval./PO Spec |  | 227d | 2008-09-17 A | 2009-08-18 A | P3J01AB FS+110d | 100% |  | E3J01A20 | E3J01A20 | 86B | 0A | 999 | 200 | 200 | 055 | E |  | LND | 0 | E | J | EJ34 | LUZ2 | OTH | LND | J01A | 2AJ2610 |  |
| E3J02D20 |  | J02D ON/OFF Plug Valves - Techn. Eval./PO Spec |  | 188d | 2008-09-26 A | 2009-07-03 A | P3J02DB FS+125d | 100% |  | E3J02D20 | E3J02D20 | 86B | 0A | 999 | 200 | 200 | 055 | E |  | LND | 0 | E | J | EJ34 | LUZ2 | PI | LND | J02D | 2AJ3020 |  |
| E3J0220 |  | J02 Control Valves - Techn. Eval./PO Spec |  | 190d | 2008-10-02 A | 2009-07-13 A | P3J02B FS+130d, F4200 FF | 100% |  | E3J0220 | E3J0220 | 86B | 0A | 999 | 200 | 200 | 055 | E |  | LND | 0 | E | J | EJ34 | LUZ2 | OTH | LND | J02 | 2AJ3030 |  |
| E3J0230 |  | J02 Control Valves -Techn. Eval./Bid Tab | milestone | 0d | 2008-11-28 A | 2008-11-28 A | E3J0215 SF, E3J0220 FF-20d | 100% |  | E3J0230 | E3J0230 | 86B | 0A | 999 | 200 | 200 | 055 | E |  | LND | 0 | E | J | EJ34 | LUZ2 | OTH | LND | J02 | 2AJ3030 |  |
| EJ000040 |  | Issue of BOQ's |  | 20d | 2009-01-05 A | 2009-01-30 A | F8810 | 100% |  | EJ000040 | EJ000040 | 86A | 0A | 999 | 200 | 200 | 070 | AD | 3A | LND | 1 | E | J | EJ00 | LUZ2 | OTH | LND |  |  |  |
| EJ000050 |  | Input for OBCE Instrumentation |  | 30d | 2009-01-05 A | 2009-02-13 A | EJ000040 FF+10d | 100% |  | EJ000050 | EJ000050 | 86A | 0A | 999 | 200 | 200 | 070 | AD | 3A | LND | 1 | E | J | EJ00 | LUZ2 | OTH | LND |  |  |  |
| E3J02C30 |  | J02C Butterfly Valves on/off-Techn.Eval./Bid Tab | milestone | 0d | 2009-03-04 A | 2009-03-04 A | P3J02CC FF-10d, E3J02C15 SF | 100% |  | E3J02C30 | E3J02C30 | 86B | 0A | 999 | 200 | 200 | 055 | E |  | LND | 0 | E | J | EJ34 | LUZ2 | PI | LND | J02C | 2AJ3090 |  |
| E3J02D30 |  | J02D ON/OFF Plug Valves -Techn.Eval./Bid Tab | milestone | 0d | 2009-03-04 A | 2009-03-04 A | E3J02D15 SF, P3J02DC FF-19d | 100% |  | E3J02D30 | E3J02D30 | 86B | 0A | 999 | 200 | 200 | 055 | E |  | LND | 0 | E | J | EJ34 | LUZ2 | PI | LND | J02D | 2AJ3020 |  |
| E3J01A30 |  | J01A Ball Valves -Techn. Eval./Bid Tab | milestone | 0d | 2009-06-24 A | 2009-06-24 A | P3J01AC FF-12d, E3J01A15 SF | 100% |  | E3J01A30 | E3J01A30 | 86B | 0A | 999 | 200 | 200 | 055 | E |  | LND | 0 | E | J | EJ34 | LUZ2 | OTH | LND | J01A | 2AJ2610 |  |
| E3J0520 |  | J05 MPS/CMS - Techn. Eval./PO Spec |  | 203d | 2009-10-27 A | 2010-08-18 A | P3J05B FS+374d | 100% | TAP [2024 h] | E3J0520 | E3J0520 | 86C | 0A | 999 | 200 | 200 | 055 | E |  | LND | 0 | E | J | EJ24 | LUZ2 | I | LND | J05 | 2JD7520 | 2024,00 |
|  | M | **M Mechanical - Rotating Equipment** |  |  | 2008-06-02 | 2008-11-28 |  |  |  |  |  |  |  |  |  |  |  |  |  |  |  |  |  |  |  |  |  |  |  |  |
| AD1140 |  | Incorporate Vendor Design Information f. 30% DRV |  | 107d | 2008-06-02 A | 2008-10-29 A | F2470 | 100% |  | AD1140 | AD1140 | 867 | 0A |  | 200 | 200 | 055 | AD | 3A | LND | 1 | E | M | 0000 | LUZ2 | INS | LND |  |  |  |
| AD1080 |  | Negotiations DCE |  | 51d | 2008-06-12 A | 2008-08-21 A | P3M05C FF, F8740 FF, P3M11C FF, P3M06C FF | 100% |  | AD1080 | AD1080 | 867 | 0A |  | 200 | 200 | 055 | AD | 3A | LND | 1 | E | M | 0000 | LUZ2 | INS | LND |  |  |  |
| AD1090 |  | Review Vendor Documents LLI/DCE |  | 119d | 2008-06-12 A | 2008-11-28 A | E3M0540 FF-15d, E3M0640 FF-6d, E3M0440 FF-4d, E3M0240 FF, E3M0340 FF, E3M0140 FF | 100% |  | AD1090 | AD1090 | 867 | 0A |  | 200 | 200 | 055 | AD | 3A | LND | 1 | E | M | 0000 | LUZ2 | INS | LND |  |  |  |
| AD1110 |  | Final bid Tabulation other rot. equipment |  | 96d | 2008-06-12 A | 2008-10-24 A | E3M0930 FF-15d, E3M1030 FF, E3M1230 FF, E3M0830 FF, AD1070 FF, E3M0730 FF | 100% |  | AD1110 | AD1110 | 867 | 0A |  | 200 | 200 | 055 | AD | 3A | LND | 1 | E | M | 0000 | LUZ2 | INS | LND |  |  |  |
| AD1120 |  | Negotiations other rot.equipment |  | 117d | 2008-06-16 A | 2008-11-28 A | P3M08C FF, P3M14C FF-15d, P3M07C FF, P3M10C FF, P3M15C FF-15d, P3M12C FF | 100% |  | AD1120 | AD1120 | 867 | 0A |  | 200 | 200 | 055 | AD | 3A | LND | 1 | E | M | 0000 | LUZ2 | INS | LND |  |  |  |
| AD1070 |  | Final bid Tabulation DCE |  | 53d | 2008-06-18 A | 2008-08-29 A | F6940 FF, F7780 FF, AD1080 FF, F7480 FF | 100% |  | AD1070 | AD1070 | 867 | 0A |  | 200 | 200 | 055 | AD | 3A | LND | 1 | E | M | 0000 | LUZ2 | INS | LND |  |  |  |

Notes:
- E3J0350: Expenses: 900A 0

| ID | WBS | Activity | Type | Duration | Start | Finish | Predecessors | Complete | UDF_SAVE ACTID | UDF_SAVE ACT ID | Department | Constr. Area | PMT-Area | PMT-Schedule Org | PMT-Phase | PMT-Stage | PMT-Respons. | Zeigen/n. Zeigen | WBS Phase | WBS Discipline | WBS Type of Work | WBS Objects | IMS | UPT | Pro Unit/DocCode | PMT-Discipline |
| --- | --- | --- | --- | --- | --- | --- | --- | --- | --- | --- | --- | --- | --- | --- | --- | --- | --- | --- | --- | --- | --- | --- | --- | --- | --- | --- |
|  | R | **R Piping** |  |  | 2008-06-20 | 2010-07-09 |  |  |  |  |  |  |  |  |  |  |  |  |  |  |  |  |  |  |  |  |
| AD2020 |  | Start up Design special piping parts |  | 113d | 2008-06-20 A | 2008-11-28 A | F2760 | 100% | AD2020 | AD2020 | 873 | 0A | 200 | 200 | AD | 3A | LND | 1 | E | R | ER00 | LUZ2 | INS | LND |  |  |
| AD2000 |  | Finalization build up Piping database for MTO |  | 68d | 2008-06-27 A | 2008-09-30 A | F2650, AD1220 FF+28d | 100% | AD2000 | AD2000 | 873 | 0A | 200 | 200 | AD | 3A | LND | 1 | E | R | ER00 | LUZ2 | INS | LND |  |  |
| AD2010 |  | Implementation standard supports in Database |  | 89d | 2008-06-27 A | 2008-10-30 A | AD2000 FF | 100% | AD2010 | AD2010 | 873 | 0A | 200 | 200 | AD | 3A | LND | 1 | E | R | ER00 | LUZ2 | INS | LND |  |  |
| AD2050 |  | Inquiry UG-Piping Materials PID Download E2 |  | 83d | 2008-07-28 A | 2008-11-24 A | AD1220 FF+10d | 100% | AD2050 | AD2050 | 873 | 0A | 200 |  | AD |  | LND | 1 | E | R | ER00 | LUZ2 | INS | LND | 91 |  |
| AD2060 |  | Inquiry AG-Piping Materials PID Download E2 |  | 43d | 2008-07-28 A | 2008-09-24 A | AD1220 FF+10d | 100% | AD2060 | AD2060 | 873 | 0A | 200 |  | AD |  | LND | 1 | E | R | ER00 | LUZ2 | INS | LND | 91 |  |
| AD2030 |  | Technical clarifications with supplier |  | 35d | 2008-10-09 A | 2008-11-28 A | AD2050 FF+4d, AD2060 FF+5d | 100% | AD2030 | AD2030 | 873 | 0A | 200 | 200 | AD | 3A | LND | 1 | E | R | ER00 | LUZ2 | INS | LND |  |  |
| A1KR0020 |  | Techn. Procurement&Dispo. Piping Mat. 1st MTO |  | 15d | 2008-12-01 A | 2008-12-19 A | A1010032 | 100% | A1KR0020 | A1KR0020 | 873 | 0A | 200 |  | E |  | LND |  | E | R | ER00 | LUZ2 | PL | LND |  |  |
| ER000165 |  | Participation 60% DSRV -downstream- | level of effort | 7d | 2009-10-19 A | 2009-10-27 A | F4035 FF, F4035 SS | 100% | ER000165 | ER000165 | 873 | 0A |  |  |  |  | LND | 1 | E | R | ER00 | LUZ2 | 2 | LND |  |  |
| ER000160 |  | Participation 60% DSRV -upstream- 11/12/13/51/55-56 | level of effort | 12d | 2009-11-02 A | 2009-11-17 A | F4035, F3060 | 100% | ER000160 | ER000160 | 873 | 0A |  |  |  |  | LND | 1 | E | R | ER00 | LUZ2 | 2 | LND |  |  |
| ER000170 |  | Participation 60% DSRV -upstream- 15/16/17/52,54 | level of effort | 15d | 2010-03-01 A | 2010-03-19 A | F4040 FF, ER000165, F4040 SS | 100% | ER000170 | ER000170 | 873 | 0A |  |  |  |  | LND | C5 | E | R | ER00 | LUZ2 | 2 | LND |  |  |
| ER000190 |  | Participation 90% DSRV -downstream- | level of effort | 10d | 2010-04-26 A | 2010-05-07 A | F9250 SS, F9250 FF, ER000170 | 100% | ER000190 | ER000190 | 873 | 0A |  |  |  |  | LND | 1 | E | R | ER00 | LUZ2 | 3 | LND |  |  |
| ER000195 |  | Participation 90% DSRV -upstream- 11/12/13/51-56 | level of effort | 15d | 2010-06-21 A | 2010-07-09 A | ER000190, F4460 FF, F4460 SS | 100% | ER000195 | ER000195 | 873 | 0A |  |  |  |  | LND | 1 | E | R | ER00 | LUZ2 | 3 | LND |  |  |
|  | S | **S Safety & Environment** |  |  | 2008-06-02 | 2008-10-30 |  |  |  |  |  |  |  |  |  |  |  |  |  |  |  |  |  |  |  |  |
| AD1300 |  | HAZOP (Licensor's Package+Utilities upstream) |  | 20d | 2008-06-02 A | 2008-06-27 A | F9000 FS+5d | 100% | AD1300 | AD1300 | 871 | 0A | 200 | 200 | AD |  | LND | 1 | E | S | ES10 | LUZ2 | INS | LND |  | 080 |
| A1CS0352 |  | HAZOP Downstream |  | 10d | 2008-06-16 A | 2008-06-27 A | AD1300 FF | 100% | A1CS0352 | A1CS0352 | 871 | 0A | 200 | 200 | AD |  |  |  | E | S | ES10 | LUZ2 | 1 | LND |  | 025 |
| AD1310 |  | HAZOP Report |  | 22d | 2008-07-16 A | 2008-08-14 A | F2390 FF+11d, AD1300, F1000 SS | 100% | AD1310 | AD1310 | 871 | 0A | 200 | 200 | AD |  | LND | 1 | E | S | ES10 | LUZ2 | INS | LND |  |  |
| AD1330 |  | Preparing PSV Specification |  | 42d | 2008-07-24 A | 2008-09-19 A | AD1220, AD1310 FF | 100% | AD1330 | AD1330 | 871 | 0A | 200 | 200 | AD |  | LND | 1 | E | S | ES20 | LUZ2 | INS | LND |  |  |
| AD1320 |  | HAZOP Follow-up |  | 68d | 2008-07-28 A | 2008-10-30 A | AD1310 FF+30d | 100% | AD1320 | AD1320 | 871 | 0A | 200 | 200 | AD |  | LND | 1 | E | S | ES10 | LUZ2 | INS | LND |  |  |
|  | Q | **Q Quality Planning/ Qualtity Assurance** |  |  | 2008-06-02 | 2008-12-30 |  |  |  |  |  |  |  |  |  |  |  |  |  |  |  |  |  |  |  |  |
| AD1600 |  | Document Review for ordered LLE/DCE |  | 120d | 2008-06-02 A | 2008-11-18 A | AD1010 FF, AD0110 FF, AD0120 FF | 100% | AD1600 | AD1600 | 883 | 0A | 200 | 200 | AD | 3A | LND | 1 | E | Q | 0000 | LUZ2 | INS | LND |  | 055 |
| AD1620 |  | Techn.supp. f. regulations weld./paint/mat.sel. |  | 120d | 2008-06-02 A | 2008-11-18 A | AD1600 FF | 100% | AD1620 | AD1620 | 883 | 0A | 200 | 200 | AD | 3A | LND | 1 | E | Q | 0000 | LUZ2 | INS | LND |  | 055 |
| AD1610 |  | Vendor Negotiations for DCE |  | 100d | 2008-06-30 A | 2008-11-18 A | AD0140 FF, AD1020 FF, AD0130 FF | 100% | AD1610 | AD1610 | 883 | 0A | 200 | 200 | AD | 3A | LND | 1 | E | Q | 0000 | LUZ2 | INS | LND |  | 055 |
| AD1630 |  | Inspections for LLE |  | 19d | 2008-12-01 A | 2008-12-30 A | F2460, F2420 | 100% | AD1630 | AD1630 | 883 | 0A | 200 | 200 | AD | 3A | LND | 1 | E | Q | 0000 | LUZ2 | INS | LND |  | 055 |

Notes:
- AD1310: P3 Activity Log Info: 4.05

| ID | WBS | Activity | Type | Duration | Start | Finish | Predecessors | Complete | Resources | UDF_SAVE ACTID | UDF_SAVE ACT ID | Department | Constr. Area | PMT-Area | PMT-Schedule Org | PMT-Discipline | PMT-Phase | PMT-Stage | PMT-Respons. | Zeigen/n. Zeigen | WBS Phase | WBS Discipline | WBS Type of Work | WBS Objects | IMS | UPT | Pro Unit/DocCode | UDF_Actictity Name (Russia) | TB26 Ressource Budget |
| --- | --- | --- | --- | --- | --- | --- | --- | --- | --- | --- | --- | --- | --- | --- | --- | --- | --- | --- | --- | --- | --- | --- | --- | --- | --- | --- | --- | --- | --- |
|  | LUZ1 | **LUZ1 Lutz Kern - Procurement** |  |  | 2008-06-02 | 2009-02-13 |  |  |  |  |  |  |  |  |  |  |  |  |  |  |  |  |  |  |  |  |  |  |  |
|  | L | **L Plant Design** |  |  | 2008-06-02 | 2009-02-13 |  |  |  |  |  |  |  |  |  |  |  |  |  |  |  |  |  |  |  |  |  |  |  |
| AD2120 |  | Check Vendor documentation special equipment |  | 126d | 2008-06-02 A | 2008-11-27 A | AD1010 FF | 100% |  | AD2120 | AD2120 | 872 | 0A | 200 | 200 | 085 | AD | 3A | LND | 1 | E | L | 0000 | LUZ1 | INS | LND |  |  |  |
| AD2100 |  | Update requirements for Pipe Stress Calculation |  | 85d | 2008-07-30 A | 2008-11-28 A | F3740 | 100% |  | AD2100 | AD2100 | 872 | 0A | 200 | 200 | 085 | AD | 3A | LND | 1 | E | L | 0000 | LUZ1 | INS | LND |  |  |  |
| AD2200 |  | Conceptual piping design (critical systems) |  | 76d | 2008-08-12 A | 2008-11-28 A | AD2230 FF+7d, AD1220 FF+28d | 100% |  | AD2200 | AD2200 | 876 | 0A | 200 |  | 050 | AD |  | LND | 1 | E | L | 0000 | LUZ1 | INS | LND | 91 |  |  |
| AD2220 |  | Incorporate Changes(P&ID Status E2) in 3D-Model |  | 59d | 2008-08-15 A | 2008-11-07 A | AD2230 FF+10d, AD1220 FF+23d | 100% |  | AD2220 | AD2220 | 876 | 0A | 200 |  | 050 | AD |  | LND | 1 | E | L | 0000 | LUZ1 | INS | LND | 91 |  |  |
| AD2210 |  | Conceptual U/G piping design finalized |  | 53d | 2008-09-12 A | 2008-11-28 A | M3T110 FF, AD1220 FF+28d | 100% |  | AD2210 | AD2210 | 876 | 0A | 200 |  | 050 | AD |  | LND | 1 | E | L | 0000 | LUZ1 | INS | LND | 91 |  |  |
| AD2110 |  | Pipe Stress Calculation for selected Pipes |  | 37d | 2008-10-07 A | 2008-11-28 A | AD1220 FS-10d | 100% |  | AD2110 | AD2110 | 872 | 0A | 200 | 200 | 085 | AD | 3A | LND | 1 | E | L | 0000 | LUZ1 | INS | LND |  |  |  |
| AD2240 |  | Plotplan Status F |  | 35d | 2008-12-22 A | 2009-02-13 A | AD2230 | 100% |  | AD2240 | AD2240 | 876 | 0A | 200 |  | 050 | AD |  | LND | 1 | E | L | 0000 | LUZ1 | INS | LND |  |  |  |
|  | 0000 | **0000 Generals - all CA's** |  |  | 2008-06-02 | 2011-04-25 |  |  |  |  |  |  |  |  |  |  |  |  |  |  |  |  |  |  |  |  |  |  |  |
|  | L | **L Plant Design** |  |  | 2008-12-15 | 2008-12-19 |  |  |  |  |  |  |  |  |  |  |  |  |  |  |  |  |  |  |  |  |  |  |  |
| AD2230 |  | 30% Design Review Part2 |  | 5d | 2008-12-15 A | 2008-12-19 A | M3R100 FF, AD1220, A1EJ0050, F3970 FS+18d, F1560, AD1400, F3920 FS+18d | 100% |  | AD2230 | AD2230 | 876 | 0A | 200 |  | 050 | AD |  | LND | L2 | E | L | ER33 | 0000 | INS | LND |  | 30% модель проекта, часть 2 |  |
|  | C | **C Civil** |  |  | 2008-06-02 | 2011-04-25 |  |  |  |  |  |  |  |  |  |  |  |  |  |  |  |  |  |  |  |  |  |  |  |
| EC15000005 |  | CA00 General - Site Survey Report |  | 209d | 2008-06-02 A | 2009-03-31 A | F4880 FF | 100% |  | EC15000005 | EC15000005 | 87A | 0A | 200 |  |  | AD |  | PMT |  | E | C | EC15 | 0000 | de | LND |  |  |  |
| EC15000010 |  | CA00 General - Piling Standardisation Program |  | 38d | 2008-11-03 A | 2008-12-30 A | X3C090 (other project) FF+20d, M3C110 FF+20d | 100% |  | EC15000010 | EC15000010 | 87A | 0A | 200 |  |  | AD |  | PMT |  | E | C | EC15 | 0000 | de | LND |  |  |  |
| P3C00A |  | Civil Det. Design Contr. - Prepare/Issue RFQ |  | 35d | 2009-01-19 A | 2009-03-06 A | AD1930, AD1900, EC000040 FF | 100% |  | P3C00A | P3C00A | 87A | 0A | 200 |  |  | AD |  | LND |  | E | C | EC00 | 0000 | E | LND |  |  |  |
| P3C00A0 |  | Civil Det. Design Contr. - Bid preparation |  | 33d | 2009-03-09 A | 2009-04-24 A | P3C00A | 100% |  | P3C00A0 | P3C00A0 | 87A | 0A | 200 |  |  | AD |  | CDC |  | E | C | EC00 | 0000 | E | LND |  |  |  |
| P3C00A05 |  | Civil Det. Design Contr. - Bid clarification |  | 5d | 2009-03-30 A | 2009-04-03 A | P3C00A | 100% |  | P3C00A05 | P3C00A05 | 87A | 0A | 200 |  |  | AD |  | CDC |  | E | C | EC00 | 0000 | E | LND |  |  |  |
| P3C00A1 |  | Civil Det. Design Contr. - Bid due date | milestone | 0d | 2009-04-24 A | 2009-04-24 A | P3C00A05, P3C00A0 FF | 100% |  | P3C00A1 | P3C00A1 | 87A | 0A | 200 |  |  | AD |  | LND |  | E | C | EC00 | 0000 | E | LND |  |  |  |
| P3C00B |  | Civil Det. Design Contr. - Bid evaluation |  | 10d | 2009-04-27 A | 2009-05-11 A | P3C00A1 | 100% |  | P3C00B | P3C00B | 87A | 0A | 200 |  |  | AD |  | LND |  | E | C | EC00 | 0000 | E | LND |  |  |  |
| P3C00C |  | Civil Det. Design Contr. - Contract negotiation CA31 |  | 59d | 2009-05-25 A | 2009-08-14 A | P3C00B FS+8d | 100% |  | P3C00C | P3C00C | 87A | 0A | 200 |  |  | AD |  | LNK |  | E | C | EC00 | 0000 | E | LND |  |  |  |
| P3C0BC |  | Civil Det. Design Contr. - Contract negotiation rem. Areas |  | 144d | 2009-05-25 A | 2009-12-14 A | P3C00B FS+8d | 100% |  | P3C0BC | P3C0BC | 87A | 0A | 200 |  |  | AD |  | IPR |  | E | C | EC00 | 0000 | E | LND |  |  |  |
| P3C00E |  | Civil Det. Design Contr. - Project setup Kaplan |  | 5d | 2009-08-10 A | 2009-08-14 A | P3C00D FF | 100% |  | P3C00E | P3C00E | 87A | 0A | 200 |  |  | AD |  | LNK | C1 | E | C | EC00 | 0000 | E | LND |  |  |  |
| E3C160 |  | CA00 General - Results of 2nd geotechn. Piling Test available | milestone | 0d | 2009-08-13 A | 2009-08-13 A | EC15000005 | 100% |  | E3C160 | E3C160 | 87A | 0A | 200 |  |  | AD |  | PMT | C1 | E | C | EC00 | 0000 | ar | LND |  |  |  |
| P3C00D |  | Civil Det. Design Contr. - Subcontract award CA31 (Kaplan) | milestone | 0d | 2009-08-14 A | 2009-08-14 A | P3C00C FF | 100% |  | P3C00D | P3C00D | 87A | 0A | 200 |  |  | AD |  | LNK | C1 | E | C | EC00 | 0000 | E | LND |  |  |  |
| E3C150 |  | CA00 General - 1st Douments (CA31) VNP TEOC approveable/available | milestone | 0d | 2009-08-19 A | 2009-08-19 A | E3C160 FF+4d | 100% |  | E3C150 | E3C150 | 87A | 0A | 200 |  |  | AD |  | PMT | C1 | E | C | EC00 | 0000 | ar | LND |  |  |  |
| EC000115 |  | Issue of Doc's "Issued for Design" to RDI |  | 308d | 2009-10-12 A | 2010-12-30 A | DE1000 | 100% | TKB-B [14344 h] | EC000115 | EC000115 | 87A | 0A | 200 |  |  | AD |  | LND |  | E | C | EC00 | 0000 | E | LND |  |  | 14344,00 |
| EC000100 |  | 3D CAD Modelling DE Phase |  | 296d | 2009-12-01 A | 2011-02-02 A | DE1000 | 100% | TKB-B [28688 h] | EC000100 | EC000100 | 87A | 0A | 200 |  |  | AD |  | LND |  | E | C | EC00 | 0000 | E | LND |  |  | 28688,00 |
| EC000125 |  | Subcontracting Civil Engineering |  | 294d | 2009-12-01 A | 2011-01-31 A | DE1000 | 100% | TKB-B [7168 h] | EC000125 | EC000125 | 87A | 0A | 200 |  |  | AD |  | LND |  | E | C | EC00 | 0000 | E | LND |  |  | 7168,00 |
| EC1000 |  | General Tasks & Coordinations DE Phase (Civil) |  | 294d | 2009-12-01 A | 2011-01-31 A | DE1000 | 100% | TKB-B [24384 h] | EC1000 | EC1000 | 87A | 0A | 200 |  |  | AD |  | LND |  | E | C | EC00 | 0000 | E | LND |  |  | 24384,00 |
| EC000105 |  | Check Manufacturer Documents (Equipment) |  | 250d | 2009-12-04 A | 2010-12-01 A | DE1000 FS+5d | 100% | TKB-B [10040 h] | EC000105 | EC000105 | 87A | 0A | 200 |  |  | AD |  | LND |  | E | C | EC00 | 0000 | E | LND |  |  | 10040,00 |
| EC000120 |  | Subcontracting Civil Contractor (up to contract) |  | 118d | 2009-12-07 A | 2010-05-31 A | DE1000, P3C02CB SS, P3C02D1 FF | 100% | TKB-B [7168 h] | EC000120 | EC000120 | 87A | 0A | 200 |  |  | AD |  | LND |  | E | C | EC00 | 0000 | E | LND |  |  | 7168,00 |
| P3C0BD |  | Civil Det. Design Contr. - Subcontract award rem. Areas (IPRO) | milestone | 0d | 2009-12-14 A | 2009-12-14 A | P3C0BC FF | 100% |  | P3C0BD | P3C0BD | 87A | 0A | 200 |  |  | AD |  | IPR | C1 | E | C | EC00 | 0000 | E | LND |  |  |  |
| EC000110 |  | Homeservice for Construction Work |  | 294d | 2009-12-21 A | 2011-02-18 A | DE1000 FS+20d | 100% | TKB-B [8608 h] | EC000110 | EC000110 | 87A | 0A | 200 |  |  | AD |  | LND |  | E | C | EC00 | 0000 | E | LND |  |  | 8608,00 |
| P3C0CD |  | Civil Det. Design Contr. - Subcontract award CA16 (AVR) | milestone | 0d | 2010-01-15 A | 2010-01-15 A | P3C0BD FF+20d | 100% |  | P3C0CD | P3C0CD | 87A | 0A | 200 |  |  | AD |  | AVR | C1 | E | C | EC00 | 0000 | E | LND |  |  |  |
| P3C0CE |  | Civil Det. Design Contr. - Subcontract award CA18 (IPRO) | milestone | 0d | 2011-04-25 A | 2011-04-25 A | P030010 FS+10d, P3C0BD FF+200d | 100% |  | P3C0CD | P3C0CE | 87A | 0A | 200 |  |  | AD |  | IPR |  | E | C | EC00 | 0000 | E | LND |  |  |  |

Notes:
- AD2200: P3 Activity Log Info: 30% + 3w
- AD2210: P3 Activity Log Info: 30% + 3w
- AD2240: P3 Activity Log Info: 30% + 3w

| ID | WBS | Activity | Duration | Start | Finish | Predecessors | Complete | Resources | UDF_SAVE ACTID | UDF_SAVE ACT ID | Department | Constr. Area | PMT-Area | PMT-Schedule Org | PMT-Discipline | PMT-Phase | PMT-Stage | PMT-Respons. | Zeigen/n. Zeigen | WBS Phase | WBS Discipline | WBS Type of Work | WBS Objects | IMS | UPT | TB26 Ressource Budget | Pro Unit/DocCode | Type of Work | Inquiry/Order No |
| --- | --- | --- | --- | --- | --- | --- | --- | --- | --- | --- | --- | --- | --- | --- | --- | --- | --- | --- | --- | --- | --- | --- | --- | --- | --- | --- | --- | --- | --- |
|  | E | **E Electrical** |  | 2008-07-01 | 2011-01-31 |  |  |  |  |  |  |  |  |  |  |  |  |  |  |  |  |  |  |  |  |  |  |  |  |
| AD1700 |  | Technical support for PU's/rot./stat.Equipm. | 44d | 2008-07-01 A | 2008-08-29 A | AD1010 FF | 100% |  | AD1700 | AD1700 | 874 | 0A | 200 | 200 | 065 | AD | 3A | LND | 1 | E | E | EE00 | 0000 | INS | LND |  |  |  |  |
| AD1730 |  | Buildings - electrical portion | 74d | 2008-07-14 A | 2008-10-24 A | F2510 FF+10d, F1580 FF+15d | 100% |  | AD1730 | AD1730 | 874 | 0A | 200 | 200 | 065 | AD | 3A | LND | 1 | E | E | EE00 | 0000 | INS | LND |  |  |  |  |
| AD1740 |  | Inquiries electrical main equipment | 97d | 2008-07-14 A | 2008-11-28 A | F2760 | 100% |  | AD1740 | AD1740 | 874 | 0A | 200 | 200 | 065 | AD | 3A | LND | 1 | E | E | EE00 | 0000 | INS | LND |  |  |  |  |
| AD1710 |  | Update Load List/ Single Line diagram | 92d | 2008-07-21 A | 2008-11-28 A | F1940, AD0120 FF | 100% |  | AD1710 | AD1710 | 874 | 0A | 200 | 200 | 065 | AD | 3A | LND | 1 | E | E | EE00 | 0000 | INS | LND |  |  |  |  |
| AD1720 |  | ETAP Calculations | 86d | 2008-07-25 A | 2008-11-26 A | AD1710 FF | 100% |  | AD1720 | AD1720 | 874 | 0A | 200 | 200 | 065 | AD | 3A | LND | 1 | E | E | EE00 | 0000 | INS | LND |  |  |  |  |
| RF1010 |  | Re-engineering and Value Awareness | 40d | 2008-10-01 A | 2008-11-28 A | F3960 | 100% |  | RF1010 | RF1010 | 874 | 0A | 200 | 200 | 070 | AD | 3A | LND | 1 | E | E | EE00 | 0000 | S | LND |  |  |  |  |
| EE460020 |  | Update Load List/ Single Line diagram | 205d | 2008-12-01 A | 2009-09-25 A | F2760 | 100% |  | EE460020 | EE460020 | 874 | 0A | 200 | 200 | 065 | E | 3B | LND | 1 | E | E | EE00 | 0000 | E | LND |  |  |  |  |
| EE460030 |  | ETAP Calculations | 325d | 2008-12-01 A | 2010-03-19 A | EE460020 FF | 100% | TAE [1600 h] | EE460030 | EE460030 | 874 | 0A | 200 | 200 | 065 | E | 3B | LND | 1 | E | E | EE00 | 0000 | E | LND | 1600,00 |  |  |  |
| EE460040 |  | Buildings - electrical portion Phase 3 | 544d | 2008-12-01 A | 2011-01-31 A | EE460030 FF+20d | 100% | TAE [1280 h] | EE460040 | EE460040 | 874 | 0A | 200 | 200 | 065 | E | 3B | LNK | 1 | E | E | EE00 | 0000 | E | LND | 1280,00 |  |  |  |
| HEE90 |  | Earthing Details / Layout Dwgs | 20d | 2009-05-22 A | 2009-06-19 A | EE903130 SS, EE901610 SS, EE903110 SS, EE903120 SS, EE903140 SS | 100% |  | HEE90 | HEE90 | 874 | 0A |  |  |  | E |  | LND | L2 | E | E | EE00 | 0000 | E | LND |  |  |  |  |
| EE000100 |  | Interface and Signal Lists - 1st issue | 49d | 2009-10-12 A | 2009-12-18 A | AD1720 FF, EE460030 FF | 100% |  | EE000100 | EE000100 | 874 | 0A |  |  |  | E |  | LND |  | E | E | EE00 | 0000 | E | LND |  |  |  |  |
|  | 0D | **0D Detailengineering All Areas** |  | 2007-12-10 | 2011-10-26 |  |  |  |  |  |  |  |  |  |  |  |  |  |  |  |  |  |  |  |  |  |  |  |  |
|  | LUZ2 | **LUZ2 General ( )** |  | 2008-04-07 | 2011-10-26 |  |  |  |  |  |  |  |  |  |  |  |  |  |  |  |  |  |  |  |  |  |  |  |  |
|  | 0B | **0B General Activities** |  | 2009-04-03 | 2011-04-25 |  |  |  |  |  |  |  |  |  |  |  |  |  |  |  |  |  |  |  |  |  |  |  |  |
| F3080 |  | Detail Engineering Part II | 520d | 2009-04-03 A | 2011-04-25 A | A1MECS02 FF, F3980, EC071300 FF, ER191332, EH30122115 FF, E3M0165 FF, EC071705 FF, EH071710 FF, EH30171815 FF, EH071730, EH30177015 FF, EH073120, EC075200 FF, EC075605 FF, EC60310012 FF, EC65120060 FF, EJ40330 FF, EJ84222, F9260, EP30020 FF, EH000040, EH000120, E3H150 FF, EE460040 FF, ETH00100 FF, ETE00100 FF, EJ000183 FF, EJ000185 FF, EJ000180 FF, EJ000182 FF, EJ000255 FF, EQ1000 FF, EL20070 FF, AD2040, HE00100 FF, EH071321 FF, EH30122215 FF, EH071222 FF, E3U0275, EH30172015 FF, EH30173015 FF, EH30312015 FF, EH073130, EC075300 FF, EC075400 FF, EC075600 FF, EC60310006 FF, EJ40370 FF, EJ75213 FF, EJ84221, EP1000 FF, AD2600, EP30030 FF, EN000040, EN250000 FF, EJ000050, EC000100 FF, EC000105 FF, ETJ00100 FF, EP20030 FF, ETN00100, EH1000 FF, A1KR0015 FF, EJ000170 FF, EJ000230 FF, EJ000250 FF, E3J0560 FF, ES100130 FF, EC20080 FF, EJ20060 FF, EC20070 FF, F4065 FF, F2890 FF, EH30132215 FF, EC071100 FF, E3A0570 FF, ER191222, ER191130 FF, E3M0370 FF, E3M0770, EH30313015 FF, EJ40350 FF, EJ00065 FF, EJ84213, EJ84211, EF000100 FF, AD1420, ETR00100 FF, ETC00100 FF, ETC00110 FF, EH1010 FF, A3KRB00110 FF, ER000250 FF, EJ000065 FF, EJ000150 FF, EJ000200 FF, EN20050 FF, PR10010 FF, EC071305 FF, EC071200 FF, EH071221 FF, EC071500 FF, EH30161015 FF, EH071718 FF, EC073105 FF, EH243110 FF, EC075305 FF, EJ40340 FF, EJ84212, AD2610, F1110, EC000125 FF, EE000290 FF, EF50010, EJ000070 FF, EJ000100 FF, EJ000225 FF, EJ000235 FF, F4060 FF, M3T140 FF, EH30132115 FF, ER191321, ER191221, EC071400 FF, EC071700 FF, EH243120 FF, EC075100 FF, EJ00050 FF, EJ84223, EJ82235, F1070, AD2510, AD2620, F1120, EN260000, EF50050 FF, EP20020 FF, EP20040 FF, EF20030 FF, EM1000 FF, ER000255 FF, ER000260 FF, ER000265 FF, EE300170 SS, E3J0760 FF, A1EJ0025 FF, EJ000220 FF, EJ000240 FF, EJ000210 FF, EL20060 FF, EC20060 FF, EH071322 FF, ER191330, EC071105 FF, ER191233, EC071600 FF, EJ800000 FF, EH071736, EH071740, EH073140, EC075405 FF, EC39120005 FF, EC0760 FF, EJ40320 FF, EJ84214, EJ00030, F5100 FF, EN250010 FF, A1010080, ETS00100 FF, ETR00110 FF, EF55400 FF, EF50020 FF, EP40010 FF, E3T150 FF, PR10020, HPB30, ER191303, EC071005 FF, EC071010 FF, EH30111015 FF, E3M0365 FF, ER191230, ER191232, EH071610 FF, EH30173615 FF, EH30174015 FF, E3M0270 FF, EC44310005 FF, EH073110, EC075105 FF, EJ40380 FF, EJ40360 FF, F4140 FF, EC000175, EC000115 FF, EL1020 FF, EL1010 FF, EE1000 SS, EC0730 FF, EF55405 FF, EE300090 FF, EJ000110 FF, EJ000181 FF, ES100300 FF, EC20090 FF, AD1370, F4540, HPM20 FF, A1MEEJ01 FF, ER191322, EH071110 FF, EB1000 FF, EC071605 FF, E3U0270 FF, E3M1265 FF, EH30171015 FF, EH071720, E3ALL470 FF, E3M0570 FF, E3M0670 FF, EH243130 FF, EH30314015 FF, EC075500 FF, EC60120050 FF, EJ84224, EJ82220, EJ00070 FF, F1020, EN250030, EC1000 FF, ETB00100 FF, EF30040 FF, ER000270 FF, EJ000060, EJ000140 FF, A1EJ0925, ES100260 FF, EF20070 FF, HE00035 FF | 100% |  | F3080 | F3080 | 007 | 0D | 200 |  |  |  |  | LND |  | E | 0B | 0000 | LUZ2 | 00 | LND |  | 91 |  |  |
| ES100103 |  | AML Extension | 9d | 2009-05-14 A | 2009-05-27 A | ES100100, ES100120 FF | 100% |  | ES100103 | ES100103 | 871 | 0D |  |  |  | E |  | PMT | FL | E | 0B | 0000 | LUZ2 | 1 | LND |  |  | A18 | 2DD0330 |
|  | P | **P Process** |  | 2008-10-06 | 2011-05-19 |  |  |  |  |  |  |  |  |  |  |  |  |  |  |  |  |  |  |  |  |  |  |  |  |
| EF20015 |  | MSB - Status F (Control/Switch Valves/inliner) | 69d | 2008-10-06 A | 2009-01-19 A | A1CF2062 FF+15d | 100% |  | EF20015 | EF20015 | 924 | 0D |  |  |  | E |  | LND |  | E | P | EF20 | LUZ2 | E | LND |  |  |  | 999 |
| EP20000 |  | Process Calculation / Process Studies | 80d | 2008-11-03 A | 2009-03-02 A | AD1050 | 100% |  | EP20000 | EP20000 | 887 | 0D | 200 | 200 | 025 | E | 3B | LND | L2 | E | P | EP20 | LUZ2 | 1 | LND |  |  |  | 999 |
| EP40010 |  | Vendor Documents Review | 500d | 2008-11-03 A | 2010-10-29 A | F8600 | 100% | CP [1760 h] | EP40010 | EP40010 | 887 | 0D | 200 | 200 | 025 | E | 3B | LND |  | E | P | EP20 | LUZ2 | 1 | LND | 1760,00 | 999 |  | 999 |
| EF40211 |  | Cause&Effects Unit 211 | 53d | 2008-11-24 A | 2009-02-11 A |  | 100% |  | EF40211 | EF40211 | 924 | 0D |  |  |  | E |  | LND |  | E | P | EF25 | LUZ2 | E | LND |  |  |  | 211 |
| EF45211 |  | Interlock/Logic Description Unit 211 | 53d | 2008-11-24 A | 2009-02-11 A | EF40211 SS | 100% |  | EF45211 | EF45211 | 924 | 0D |  |  |  | E |  | LND |  | E | P | EF25 | LUZ2 | 1 | LND |  |  |  | 211 |
| EF50211 |  | Control Narratives Unit 211 | 53d | 2008-11-24 A | 2009-02-11 A | EF45211 SS | 100% |  | EF50211 | EF50211 | 924 | 0D |  |  |  | E |  | LND |  | E | P | EF25 | LUZ2 | 1 | LND |  |  |  | 211 |
| A1CF0235 |  | P&ID Status F | 55d | 2008-12-01 A | 2009-02-20 A | AD1220 FF+85d, AD2230 FF+20d, A1CF2052, A1CF2062 | 100% |  | A1CF0235 | A1CF0235 | 924 | 0D | 200 |  |  | E |  | LND | L2 | E | P | EF10 | LUZ2 | ML | LND |  |  |  | 999 |
| EF40212 |  | Cause&Effects Unit 212 | 60d | 2008-12-01 A | 2009-02-27 A | EF40211 SS | 100% |  | EF40212 | EF40212 | 924 | 0D |  |  |  | E |  | LND |  | E | P | EF25 | LUZ2 | E | LND |  |  |  | 212 |
| EF45212 |  | Interlock/Logic Description Unit 212 | 60d | 2008-12-01 A | 2009-02-27 A | EF40212 SS | 100% |  | EF45212 | EF45212 | 924 | 0D |  |  |  | E |  | LND |  | E | P | EF25 | LUZ2 | 1 | LND |  |  |  | 212 |
| EF50212 |  | Control Narratives Unit 212 | 60d | 2008-12-01 A | 2009-02-27 A | EF45212 SS | 100% |  | EF50212 | EF50212 | 924 | 0D |  |  |  | E |  | LND |  | E | P | EF25 | LUZ2 | 1 | LND |  |  |  | 212 |
| EF55212 |  | Sequences Unit 212 | 60d | 2008-12-01 A | 2009-02-27 A | EF50212 SS, EF55218 FF | 100% |  | EF55212 | EF55212 | 924 | 0D |  |  |  | E |  | LND |  | E | P | EF25 | LUZ2 | 1 | LND |  |  |  | 212 |
| EF55405 |  | Instrum. + Functional Planning/ Design/Review | 510d | 2008-12-01 A | 2010-12-10 A | EJ40305 FF | 100% | CB [2000 h] | EF55405 | EF55405 | 924 | 0D |  |  |  | E |  | LND |  | E | P | EF25 | LUZ2 | 1 | LND | 2000,00 | 999 |  | 400 |
| EP20030 |  | Engineering support for Departments | 502d | 2008-12-01 A | 2010-11-30 A | AD1010, IMS-E-000010 FF | 100% | CP [800 h] | EP20030 | EP20030 | 887 | 0D | 200 | 200 |  | E | 3B | LND |  | E | P | EP20 | LUZ2 | 1 | LND | 800,00 | 999 |  | 999 |
| EF40300 |  | Cause&Effects Utilities | 40d | 2008-12-08 A | 2009-02-06 A | EF40211 SS | 100% |  | EF40300 | EF40300 | 924 | 0D |  |  |  | E |  | LND |  | E | P | EF25 | LUZ2 | E | LND |  |  |  | 000 |
| EF45300 |  | Interlock/Logic Description Utilities | 40d | 2008-12-08 A | 2009-02-06 A | EF40300 SS | 100% |  | EF45300 | EF45300 | 924 | 0D |  |  |  | E |  | LND |  | E | P | EF25 | LUZ2 | 1 | LND |  |  |  | 000 |
| EF50300 |  | Control Narratives Utilities | 40d | 2008-12-08 A | 2009-02-06 A | EF45300 SS | 100% |  | EF50300 | EF50300 | 924 | 0D |  |  |  | E |  | LND |  | E | P | EF25 | LUZ2 | 1 | LND |  |  |  | 000 |
| EF40210 |  | Cause&Effects Unit 210 | 25d | 2009-01-12 A | 2009-02-13 A | EF40300 SS | 100% |  | EF40210 | EF40210 | 924 | 0D |  |  |  | E |  | LND |  | E | P | EF25 | LUZ2 | E | LND |  |  |  | 210 |
| EF40213 |  | Cause&Effects Unit 213 | 40d | 2009-01-12 A | 2009-03-06 A | EF40211 SS | 100% |  | EF40213 | EF40213 | 924 | 0D |  |  |  | E |  | LND |  | E | P | EF25 | LUZ2 | E | LND |  |  |  | 213 |
| EF40218 |  | Cause&Effects Unit 218 | 30d | 2009-01-12 A | 2009-02-20 A | EF40211 SS | 100% |  | EF40218 | EF40218 | 924 | 0D |  |  |  | E |  | LND |  | E | P | EF25 | LUZ2 | E | LND |  |  |  | 218 |
| EF45210 |  | Interlock/Logic Description Unit 210 | 25d | 2009-01-12 A | 2009-02-13 A | EF40210 SS | 100% |  | EF45210 | EF45210 | 924 | 0D |  |  |  | E |  | LND |  | E | P | EF25 | LUZ2 | 1 | LND |  |  |  | 210 |
| EF45213 |  | Interlock/Logic Description Unit 213 | 40d | 2009-01-12 A | 2009-03-06 A | EF40213 SS | 100% |  | EF45213 | EF45213 | 924 | 0D |  |  |  | E |  | LND |  | E | P | EF25 | LUZ2 | 1 | LND |  |  |  | 213 |
| EF45218 |  | Interlock/Logic Description Unit 218 | 30d | 2009-01-12 A | 2009-02-20 A | EF40218 SS | 100% |  | EF45218 | EF45218 | 924 | 0D |  |  |  | E |  | LND |  | E | P | EF25 | LUZ2 | 1 | LND |  |  |  | 218 |
| EF50210 |  | Control Narratives Unit 210 | 25d | 2009-01-12 A | 2009-02-13 A | EF45210 SS | 100% |  | EF50210 | EF50210 | 924 | 0D |  |  |  | E |  | LND |  | E | P | EF25 | LUZ2 | 1 | LND |  |  |  | 210 |
| EF50213 |  | Control Narratives Unit 213 | 40d | 2009-01-12 A | 2009-03-06 A | EF45213 SS | 100% |  | EF50213 | EF50213 | 924 | 0D |  |  |  | E |  | LND |  | E | P | EF25 | LUZ2 | 1 | LND |  |  |  | 213 |
| EF50218 |  | Control Narratives Unit 218 | 30d | 2009-01-12 A | 2009-02-20 A | EF45218 SS | 100% |  | EF50218 | EF50218 | 924 | 0D |  |  |  | E |  | LND |  | E | P | EF25 | LUZ2 | 1 | LND |  |  |  | 218 |
| EF55213 |  | Sequences Unit 213 | 40d | 2009-01-12 A | 2009-03-06 A | EF55212 FF, EF50213 SS | 100% |  | EF55213 | EF55213 | 924 | 0D |  |  |  | E |  | LND |  | E | P | EF25 | LUZ2 | 1 | LND |  |  |  | 213 |
| EF55218 |  | Sequences Unit 218 | 30d | 2009-01-12 A | 2009-02-20 A | EF50218 SS | 100% |  | EF55218 | EF55218 | 924 | 0D |  |  |  | E |  | LND |  | E | P | EF25 | LUZ2 | 1 | LND |  |  |  | 218 |
| EF40214 |  | Cause&Effects Unit 214 | 50d | 2009-01-26 A | 2009-04-03 A | EF40211 SS | 100% |  | EF40214 | EF40214 | 924 | 0D |  |  |  | E |  | LND |  | E | P | EF25 | LUZ2 | E | LND |  |  |  | 214 |
| EF40215 |  | Cause&Effects Unit 215 | 50d | 2009-01-26 A | 2009-04-03 A | EF40211 SS | 100% |  | EF40215 | EF40215 | 924 | 0D |  |  |  | E |  | LND |  | E | P | EF25 | LUZ2 | E | LND |  |  |  | 215 |
| EF40320 |  | JSW - Funct. Design Requirements - Break (Slow Down) | 40d | 2009-01-26 A | 2009-03-20 A | EF40214 SS | 100% |  | EF40320 | EF40320 | 924 | 0D |  |  |  | E |  | LND |  | E | P | EF25 | LUZ2 | E | LND |  |  |  | 020 |
| EF40330 |  | Zeppelin - Funct. Design Requirements | 132d | 2009-01-26 A | 2009-08-04 A | EF40214 SS | 100% |  | EF40330 | EF40330 | 924 | 0D |  |  |  | E |  | LND |  | E | P | EF25 | LUZ2 | E | LND |  | 999 |  | 020 |
| EF40340 |  | K-Tron - Funct. Design Requirements | 86d | 2009-01-26 A | 2009-05-29 A | EF40214 SS | 100% |  | EF40340 | EF40340 | 924 | 0D |  |  |  | E |  | LND |  | E | P | EF25 | LUZ2 | E | LND |  |  |  | 020 |
| EF40360 |  | Sundstrand - Funct. Design Requirements | 96d | 2009-01-26 A | 2009-06-15 A | EF40214 SS | 100% |  | EF40360 | EF40360 | 924 | 0D |  |  |  | E |  | LND |  | E | P | EF25 | LUZ2 | E | LND |  |  |  | 020 |
| EF45214 |  | Interlock/Logic Description Unit 214 | 50d | 2009-01-26 A | 2009-04-03 A | EF40214 SS | 100% |  | EF45214 | EF45214 | 924 | 0D |  |  |  | E |  | LND |  | E | P | EF25 | LUZ2 | 1 | LND |  |  |  | 214 |
| EF45215 |  | Interlock/Logic Description Unit 215 | 50d | 2009-01-26 A | 2009-04-03 A | EF40215 SS | 100% |  | EF45215 | EF45215 | 924 | 0D |  |  |  | E |  | LND |  | E | P | EF25 | LUZ2 | 1 | LND |  |  |  | 215 |
| EF50214 |  | Control Narratives Unit 214 | 50d | 2009-01-26 A | 2009-04-03 A | EF45214 SS | 100% |  | EF50214 | EF50214 | 924 | 0D |  |  |  | E |  | LND |  | E | P | EF25 | LUZ2 | 1 | LND |  |  |  | 214 |
| EF50215 |  | Control Narratives Unit 215 | 50d | 2009-01-26 A | 2009-04-03 A | EF45215 SS | 100% |  | EF50215 | EF50215 | 924 | 0D |  |  |  | E |  | LND |  | E | P | EF25 | LUZ2 | 1 | LND |  |  |  | 215 |
| EF55214 |  | Sequences Unit 214 | 50d | 2009-01-26 A | 2009-04-03 A | EF55213 FF, EF50214 SS | 100% |  | EF55214 | EF55214 | 924 | 0D |  |  |  | E |  | LND |  | E | P | EF25 | LUZ2 | 1 | LND |  |  |  | 214 |
| EF55215 |  | Sequences Unit 215 | 50d | 2009-01-26 A | 2009-04-03 A | EF55214 FF, EF50215 SS | 100% |  | EF55215 | EF55215 | 924 | 0D |  |  |  | E |  | LND |  | E | P | EF25 | LUZ2 | 1 | LND |  |  |  | 215 |
| EF30010 |  | Basic Specifications for Strainers | 5d | 2009-02-02 A | 2009-02-06 A | F4380 | 100% |  | EF30010 | EF30010 | 924 | 0D |  |  |  | E |  | LND |  | E | P | EF40 | LUZ2 | E | LND |  |  |  | 999 |
| EF30020 |  | Basic Specifications for Steam Traps | 5d | 2009-02-02 A | 2009-02-06 A | F4380 | 100% |  | EF30020 | EF30020 | 924 | 0D |  |  |  | E |  | LND |  | E | P | EF40 | LUZ2 | E | LND |  |  |  | 999 |
| EP20040 |  | Update of Utility Consumpt. (final) -F- | 20d | 2009-02-02 A | 2009-02-27 A | AD1050 | 100% |  | EP20040 | EP20040 | 887 | 0D | 200 | 200 |  | E | 3A | LND | L2 | E | P | EP20 | LUZ2 | 1 | LND |  |  |  | 999 |
| EP20045 |  | Update of Process Description (final) -F- | 30d | 2009-02-02 A | 2009-03-13 A | AD1160 | 100% |  | EP20045 | EP20045 | 887 | 0D | 200 | 200 |  | E | 3A | LND | L2 | E | P | EP20 | LUZ2 | 1 | LND |  |  |  | 999 |
| EP20050 |  | Update Material Balance (final) -F- | 20d | 2009-02-02 A | 2009-02-27 A | AD1160 | 100% |  | EP20050 | EP20050 | 887 | 0D | 200 | 200 |  | E | 3A | LND | L2 | E | P | EP20 | LUZ2 | 1 | LND |  |  |  | 999 |
| EF20025 |  | MSB - Status E (DCS/PLC + Local Instruments) | 43d | 2009-02-05 A | 2009-04-06 A | A1CF0235 FF+15d, EF20015 | 100% |  | EF20025 | EF20025 | 924 | 0D |  |  |  | E |  | LND |  | E | P | EF20 | LUZ2 | E | LND |  |  |  | 999 |
| EF30030 |  | Basic Specifications for Orifices | 10d | 2009-02-09 A | 2009-02-20 A | EF30010, EF30020 | 100% |  | EF30030 | EF30030 | 924 | 0D |  |  |  | E |  | LND |  | E | P | EF40 | LUZ2 | E | LND |  |  |  | 999 |
| EP20035 |  | Update of Process Flow Diagrams (final) -F- | 25d | 2009-02-09 A | 2009-03-13 A | F2720 | 100% |  | EP20035 | EP20035 | 887 | 0D | 200 | 200 |  | E | 3A | LND | L2 | E | P | EP40 | LUZ2 | 1 | LND |  |  |  | 999 |
| EF50010 |  | Interface List Status G - prelim. | 2d | 2009-02-24 A | 2009-02-25 A | A1CF0235 FF | 100% |  | EF50010 | EF50010 | 924 | 0D |  |  |  | E |  | LND |  | E | P | EF50 | LUZ2 | 1 | LND |  |  |  | 999 |
| EF50020 |  | Alarm and Trip Setting List (+ Alarm Priorities) | 10d | 2009-03-24 A | 2009-04-06 A | A1CF0235 FF, EF20025 FF | 100% |  | EF50020 | EF50020 | 924 | 0D |  |  |  | E |  | LND |  | E | P | EF50 | LUZ2 | 1 | LND |  |  |  | 999 |
| EF40350 |  | Burckhardt - Funct. Design Requirements - Break (Slow Down) | 150d | 2009-03-30 A | 2009-10-30 A | EF40214 SS | 100% |  | EF40350 | EF40350 | 924 | 0D |  |  |  | E |  | LND |  | E | P | EF25 | LUZ2 | E | LND |  |  |  | 020 |
| EF00100 |  | P&ID update all Systems Status H2 | 540d | 2009-04-01 A | 2011-05-19 A | IMS-E-000030 FF, IMS-E-000050 FF, IMS-E-000010 FF, IMS-E-000045 FF, EF00110 FF | 100% | CB [30400 h] | EF00100 | EF00100 | 924 | 0D | 200 |  |  | E |  | LND | L2 | E | P | EF10 | LUZ2 | E | LND | 30400,00 | 999 |  | 999 |
| A1CF0255 |  | Basic definitions pre-/comm. sequences | 25d | 2009-08-21 A | 2009-09-24 A | IMS-E-000020 SS | 100% |  | A1CF0255 | A1CF0255 | 924 | 0D | 200 |  |  | E |  | LND |  | E | P | EF60 | LUZ2 | 1 | LND |  | 999 |  | 999 |

Notes:
- HEE90: UDF_Actictity Name (Russia): Узлы заземления / компоновочные чертежи
- EP20000: UDF_Actictity Name (Russia): Расчет / анализ технологического процесса
- A1CF0235: P3 Activity Log Info: AFCD = approved f. Completion Detail Engineering / UDF_Actictity Name (Russia): P&ID, статус F
- EP20040: UDF_Actictity Name (Russia): Обновление данных потребления ОЗХ (окончательно) -F-
- EP20045: UDF_Actictity Name (Russia): Обновление описания производственного процесса (окончательно) -F-
- EP20050: UDF_Actictity Name (Russia): Обновление материального баланса (окончательно) -F-
- EP20035: UDF_Actictity Name (Russia): Обновление технологических схем (окончательно) -F-
- EF00100: P3 Activity Log Info: AFCD = approved f. Completion Detail / Engineering / UDF_Actictity Name (Russia): Обновление P&ID всех систем

| ID | Activity | Duration | Start | Finish | Predecessors | Complete | Resources | UDF_Actictity Name (Russia) | UDF_SAVE ACTID | UDF_SAVE ACT ID | Department | Constr. Area | Pro Unit/DocCode | Inquiry/Order No | PMT-Area | PMT-Phase | PMT-Respons. | Zeigen/n. Zeigen | WBS Phase | WBS Discipline | WBS Type of Work | WBS Objects | IMS | UPT | TB26 Ressource Budget | PMT-Schedule Org | PMT-Stage |
| --- | --- | --- | --- | --- | --- | --- | --- | --- | --- | --- | --- | --- | --- | --- | --- | --- | --- | --- | --- | --- | --- | --- | --- | --- | --- | --- | --- |
| IMS-E-000020 | P&ID Status G Part I | 109d | 2009-08-21 A | 2010-01-27 A | A1010024, F4030 FF+28d, F4035 FF+15d | 100% |  | P&ID, статус G | IMS-E-000020 | IMS-E-000020 | 924 | 0D | 999 | 999 | 200 | E | LND | L2 | E | P | EF10 | LUZ2 | 2 | IMS |  |  |  |
| A1CF0240 | Operating Manual | 415d | 2009-09-25 A | 2011-05-16 A | A1CF0255, EF40020 FF+5d, F4460 FF | 100% | CB [25600 h] |  | A1CF0240 | A1CF0240 | 924 | 0D | 999 | 999 | 200 | E | LND |  | E | P | EF60 | LUZ2 | 1 | LND | 25600,00 |  |  |
| EF20030 | MSB - Status H (DCS/Valves/Instruments) | 220d | 2009-11-16 A | 2010-09-30 A | EF20025 | 100% |  |  | EF20030 | EF20030 | 924 | 0D |  | 999 |  | E | LND |  | E | P | EF20 | LUZ2 | E | LND |  |  |  |
| EF40325 | JSW - Funct. Design Requirements - Restart | 40d | 2009-11-16 A | 2010-01-15 A | EF40320 | 100% |  |  | EF40325 | EF40325 | 924 | 0D | 999 | 020 |  | E | LND |  | E | P | EF25 | LUZ2 | E | LND |  |  |  |
| EF40355 | Burckhardt - Funct. Design Requirements - Restart | 40d | 2009-11-23 A | 2010-01-21 A | EF40350 | 100% |  |  | EF40355 | EF40355 | 924 | 0D | 999 | 020 |  | E | LND |  | E | P | EF25 | LUZ2 | E | LND |  |  |  |
| EF50050 | Battery Limits Status H / Interface List | 235d | 2009-11-25 A | 2010-10-29 A | IMS-E-000020 SS+40d | 100% | CB [840 h] |  | EF50050 | EF50050 | 924 | 0D |  | 999 |  | E | LND |  | E | P | EF50 | LUZ2 | 1 | LND | 840,00 |  |  |
| EF30040 | Specifications Layout-DCS/ Screen graphics | 125d | 2009-11-26 A | 2010-05-31 A | F4035 FS+20d | 100% | CB [2512 h] |  | EF30040 | EF30040 | 924 | 0D | 999 | 999 |  | E | LND |  | E | P | EF20 | LUZ2 | E | LND | 2512,00 |  |  |
| EP40000 | Process Flow - & Block Flow Diagramms (final) -H- | 209d | 2009-12-02 A | 2010-09-30 A | IMS-E-000010 FF, EF000110 FF, EP30010 FF, DE1000 | 100% | CP [1400 h] |  | EP40000 | EP40000 | 887 | 0D |  | 999 | 200 | E | LND |  | E | P | EP40 | LUZ2 | 1 | LND | 1400,00 | 200 | 3B |
| A1CF0245 | Precommissioning & Turnover + Planning | 214d | 2009-12-07 A | 2010-10-12 A | A1CF0240 SS+10d, EF60010, IMS-E-000010 FF, A1010024 FS+20d | 100% | CB [4000 h] |  | A1CF0245 | A1CF0245 | 924 | 0D |  | 999 | 200 | E | LND |  | E | P | EF60 | LUZ2 | 1 | LND | 4000,00 |  |  |
| EF000110 | Process Flow - & Block Flow Diagramms - Drafts- | 150d | 2009-12-07 A | 2010-07-14 A | DE1000 FS+30d, EP20035 | 100% | CB [480 h] |  | EF000110 | EF000110 | 924 | 0D |  | 999 | 200 | E | LND |  | E | P | 0000 | LUZ2 | 1 | LND | 480,00 | 200 | 3B |
| EP30010 | Specification of Effluents H | 189d | 2009-12-14 A | 2010-09-14 A | EP30000 FF, DE1000 | 100% | CP [160 h] |  | EP30010 | EP30010 | 887 | 0D |  | 999 | 200 | E | LND |  | E | P | EP30 | LUZ2 | 1 | LND | 160,00 | 200 | 3B |
| EP20020 | Update of Process Description -H- | 199d | 2009-12-16 A | 2010-09-30 A | DE1000, EP20010 FF | 100% | CP [160 h] |  | EP20020 | EP20020 | 887 | 0D |  | 999 | 200 | E | LND |  | E | P | EP20 | LUZ2 | 1 | LND | 160,00 | 200 | 3B |
| EF40400 | Revision Cause&Effects | 25d | 2010-01-22 A | 2010-02-25 A | EF40320, EF40355, EF40330 FF, EF40340 FF, EF40350, EF40360, IMS-E-000020 FF+20d | 100% |  |  | EF40400 | EF40400 | 924 | 0D |  | 400 |  | E | LND |  | E | P | EF25 | LUZ2 | 1 | LND |  |  |  |
| EF45400 | Revision Interlock/Logic Description | 25d | 2010-01-22 A | 2010-02-25 A | EF40400 SS | 100% |  |  | EF45400 | EF45400 | 924 | 0D |  | 400 |  | E | LND |  | E | P | EF25 | LUZ2 | 1 | LND |  |  |  |
| EF50400 | Revision Control Narratives | 25d | 2010-01-22 A | 2010-02-25 A | EF45400 SS | 100% |  |  | EF50400 | EF50400 | 924 | 0D |  | 400 |  | E | LND |  | E | P | EF25 | LUZ2 | 1 | LND |  |  |  |
| EF55400 | Revision Sequences | 25d | 2010-01-22 A | 2010-02-25 A | EF50400 SS, EF55215 | 100% |  |  | EF55400 | EF55400 | 924 | 0D |  | 400 |  | E | LND |  | E | P | EF25 | LUZ2 | 1 | LND |  |  |  |
| EF60010 | Commissioning Sequences | 10d | 2010-01-28 A | 2010-02-10 A | IMS-E-000020 | 100% |  |  | EF60010 | EF60010 | 924 | 0D |  | 999 |  | E | INE |  | E | P | EF60 | LUZ2 | 1 | LND |  |  |  |
| IMS-E-000025 | P&ID Status G Part II | 20d | 2010-03-22 A | 2010-04-20 A | F4040 | 100% |  | P&ID, статус G | IMS-E-000025 | IMS-E-000025 | 924 | 0D | 999 | 999 | 200 | E | LND | L2 | E | P | EF10 | LUZ2 | 2 | IMS |  |  |  |
| EP30000 | Raw Material,catalyst&Chemicals summ H | 74d | 2010-06-03 A | 2010-09-14 A | F4460 FF+13d, F9250, IMS-E-000020 | 100% | CP [64 h] |  | EP30000 | EP30000 | 887 | 0D |  | 999 | 200 | E | LND |  | E | P | EP30 | LUZ2 | 1 | LND | 64,00 | 200 | 3B |
| EP20010 | Utility Consumption H (final) | 71d | 2010-06-24 A | 2010-09-30 A | EP30000 FF+2d | 100% | CP [240 h] |  | EP20010 | EP20010 | 887 | 0D |  | 999 | 200 | E | LND |  | E | P | EP20 | LUZ2 | 1 | LND | 240,00 | 200 | 3B |
| EF40002 | DCS SW Typical Test (YEF-G) | 6d | 2010-07-07 A | 2010-07-14 A |  | 100% |  |  | EF40002 | EF40002 | 924 | 0D | 999 | 999 |  | E | LND |  | E | P | EF28 | LUZ2 | E | LND |  |  |  |
| EF40003 | DCS Review Graphics Typicals | 10d | 2010-08-03 A | 2010-08-16 A | P3J06X0 FF | 100% |  |  | EF40003 | EF40003 | 924 | 0D | 999 | 999 |  | E | LND |  | E | P | EF28 | LUZ2 | E | LND |  |  |  |
| IMS-E-000030 | P&ID Status H1 (intermediate) AFC | 87d | 2010-08-25 A | 2010-12-27 A | IMS-E-000025 FS+15d | 100% |  | P&ID, статус H (окончательно - после проверки ISO) AFC | IMS-E-000030 | IMS-E-000030 | 924 | 0D |  | 999 | 200 | E | LND | L2 | E | P | EF10 | LUZ2 | 2 | IMS |  |  |  |
| IMS-E-000043 | P&ID Status H (final) AFC - CA51 | 50d | 2010-10-15 A | 2010-12-27 A | ER495101 FF+5d, ER495102 FF+5d, ER495104 FF+5d, ER495103 FF+5d | 100% |  | P&ID, статус H (окончательно - после проверки ISO) AFC | IMS-E-000043 | IMS-E-000043 | 924 | 0D |  | 999 | 200 | E | LND | L2 | E | P | EF10 | LUZ2 | 2 | IMS |  |  |  |
| EF40006 | DCS SW Pre-FAT (YEF-G) | 30d | 2010-11-01 A | 2010-12-13 A | EF40003, EF40004 SS-9d | 100% |  |  | EF40006 | EF40006 | 924 | 0D | 999 | 999 |  | E | LND |  | E | P | EF28 | LUZ2 | E | LND |  |  |  |
| IMS-E-000040 | P&ID Status H (final) AFC - CA11 | 30d | 2010-11-03 A | 2010-12-15 A | ER491110 FF+5d | 100% |  | P&ID, статус H (окончательно - после проверки ISO) AFC | IMS-E-000040 | IMS-E-000040 | 924 | 0D |  | 999 | 200 | E | LND | L2 | E | P | EF10 | LUZ2 | 2 | IMS |  |  |  |
| IMS-E-000041 | P&ID Status H (final) AFC - CA12 | 30d | 2010-11-05 A | 2010-12-17 A | ER491204 FF, ER491232 FF, ER491230 FF, ER491221 FF, ER491222 FF, ER491201 FF | 100% |  | P&ID, статус H (окончательно - после проверки ISO) AFC | IMS-E-000041 | IMS-E-000041 | 924 | 0D |  | 999 | 200 | E | LND | L2 | E | P | EF10 | LUZ2 | 2 | IMS |  |  |  |
| EF00110 | P&ID Status H1 (intermediate) AFC - CA17 | 30d | 2010-11-12 A | 2010-12-27 A | ER491707 SF+30d, ER491740 SF+30d, ER491720 SF+30d, ER491730 SF+30d, ER491760 SF+33d, ER491718 SF+30d, ER491736 SF+30d, ER491708 SF+30d, ER491710 SF+30d | 100% |  | P&ID, статус H (окончательно - после проверки ISO) AFC | EF00110 | EF00110 | 924 | 0D |  | 999 | 200 | E | LND | L2 | E | P | EF10 | LUZ2 | 2 | IMS |  |  |  |
| EF40004 | DCS SW Integration (YEF-G) | 15d | 2010-11-12 A | 2010-12-03 A | EF40002 | 100% |  |  | EF40004 | EF40004 | 924 | 0D | 999 | 999 |  | E | LND |  | E | P | EF28 | LUZ2 | E | LND |  |  |  |
| IMS-E-000035 | P&ID Status H (final) AFC - CA31 | 25d | 2010-11-12 A | 2010-12-17 A | ER493130 FF, ER493110 FF, ER493120 FF, ER493140 FF | 100% |  | P&ID, статус H (окончательно - после проверки ISO) AFC | IMS-E-000035 | IMS-E-000035 | 924 | 0D |  | 999 | 200 | E | LND | L2 | E | P | EF10 | LUZ2 | 2 | IMS |  |  |  |
| IMS-E-000042 | P&ID Status H (final) AFC - CA13 | 30d | 2010-11-12 A | 2010-12-27 A | ER491330 FF+2d, ER491304 FF+2d, ER491322 FF+2d, ER491332 FF+2d, ER491301 FF, ER491321 FF+2d | 100% |  | P&ID, статус H (окончательно - после проверки ISO) AFC | IMS-E-000042 | IMS-E-000042 | 924 | 0D |  | 999 | 200 | E | LND | L2 | E | P | EF10 | LUZ2 | 2 | IMS |  |  |  |
| IMS-E-000046 | P&ID Status H (final) AFC - CA52/54/55/56 | 30d | 2010-11-12 A | 2010-12-27 A | ER495503 FF+4d, ER495601 FF+5d, ER495501 FF+4d, ER495401 FF+4d, ER495402 FF+4d, ER495502 FF+4d, ER495201 FF+5d | 100% |  | P&ID, статус H (окончательно - после проверки ISO) AFC | IMS-E-000046 | IMS-E-000046 | 924 | 0D |  | 999 | 200 | E | LND | L2 | E | P | EF10 | LUZ2 | 2 | IMS |  |  |  |
| EF40010 | DCS SW FAT (YEF-G) | 54d | 2010-12-06 A | 2011-02-21 A | P3J06X1 FF | 100% |  |  | EF40010 | EF40010 | 924 | 0D | 999 | 999 |  | E | LND |  | E | P | EF28 | LUZ2 | E | LND |  |  |  |
| EF40015 | DCS HW internal test/Pre-FAT (YRU) | 30d | 2011-01-14 A | 2011-02-24 A | EF40010 FF, P3J06X2 FF | 100% |  |  | EF40015 | EF40015 | 924 | 0D | 999 | 999 |  | E | LND |  | E | P | EF28 | LUZ2 | E | LND |  |  |  |
| EF40020 | DCS HW and IFAT (YEF-G, YRU) | 15d | 2011-03-01 A | 2011-03-21 A | EF40015, P3J06X3 FF | 100% |  |  | EF40020 | EF40020 | 924 | 0D | 999 | 999 |  | E | LND |  | E | P | EF28 | LUZ2 | E | LND |  |  |  |
| IMS-E-000045 | P&ID Status H 2 (final) AFC - CA17 | 30d | 2011-03-15 A | 2011-04-25 A | ER491707 FF+15d, ER491740 FF+10d, ER491718 FF+10d, ER491760 FF+10d, ER491710 FF+10d, ER491730 FF+10d, ER491736 FF+10d, ER491708 FF+15d, ER491720 FF+10d | 100% |  | P&ID, статус H (окончательно - после проверки ISO) AFC | IMS-E-000045 | IMS-E-000045 | 924 | 0D |  | 999 | 200 | E | LND | L2 | E | P | EF10 | LUZ2 | 2 | IMS |  |  |  |
| IMS-E-000050 | P&ID Status H (final) AFC - CA10/14/53 | 48d | 2011-03-15 A | 2011-05-19 A | ER491010 FF+15d, IMS-E-000010 FF, ER491510 FF+15d, ER495301 FF+10d, ER491410 FF+5d, ER491130 FF+10d | 100% |  | P&ID, статус H (окончательно - после проверки ISO) AFC | IMS-E-000050 | IMS-E-000050 | 924 | 0D |  | 999 | 200 | E | LND | L2 | E | P | EF10 | LUZ2 | 2 | IMS |  |  |  |
| EF00210 | P&ID Issue for Detail Design - Central Chiller Unit | 20d | 2011-04-12 A | 2011-05-09 A | P030010 | 100% |  | P&ID, статус H (окончательно - после проверки ISO) AFC | EF00110 | EF00210 | 924 | 0D |  | 999 | 200 | E | LND | L2 | E | P | EF10 | LUZ2 | 2 | IMS |  |  |  |

Notes:
- IMS-E-000020: P3 Activity Log Info: AFCD = approved f. Completion Detail Engineering
- IMS-E-000025: P3 Activity Log Info: AFCD = approved f. Completion Detail Engineering
- IMS-E-000030: P3 Activity Log Info: AFCD = approved f. / Completion Detail Engineering
- IMS-E-000043: P3 Activity Log Info: AFCD = approved f. / Completion Detail Engineering
- IMS-E-000040: P3 Activity Log Info: AFCD = approved f. / Completion Detail Engineering
- IMS-E-000041: P3 Activity Log Info: AFCD = approved f. / Completion Detail Engineering
- EF00110: P3 Activity Log Info: AFCD = approved f. / Completion Detail Engineering
- IMS-E-000035: P3 Activity Log Info: AFCD = approved f. / Completion Detail Engineering
- IMS-E-000042: P3 Activity Log Info: AFCD = approved f. / Completion Detail Engineering
- IMS-E-000046: P3 Activity Log Info: AFCD = approved f. / Completion Detail Engineering
- IMS-E-000045: P3 Activity Log Info: AFCD = approved f. / Completion Detail Engineering
- IMS-E-000050: P3 Activity Log Info: AFCD = approved f. / Completion Detail Engineering
- EF00210: P3 Activity Log Info: AFCD = approved f. / Completion Detail Engineering

| ID | WBS | Activity | Type | Duration | Start | Finish | Predecessors | Complete | Total float | Free float | Resources | Cost | Actual cost | UDF_SAVE ACTID | UDF_SAVE ACT ID | Department | Constr. Area | Pro Unit/DocCode | PMT-Area | PMT-Schedule Org | PMT-Discipline | PMT-Phase | PMT-Stage | PMT-Respons. | Zeigen/n. Zeigen | WBS Phase | WBS Discipline | WBS Type of Work | WBS Objects | IMS | UPT | UDF_Actictity Name (Russia) | Inquiry/Order No | TB26 Ressource Budget | Type of Work | PMT-Doc. Type |
| --- | --- | --- | --- | --- | --- | --- | --- | --- | --- | --- | --- | --- | --- | --- | --- | --- | --- | --- | --- | --- | --- | --- | --- | --- | --- | --- | --- | --- | --- | --- | --- | --- | --- | --- | --- | --- |
|  | L | **L Plant Design** |  |  | 2008-09-29 | 2011-10-26 |  |  |  |  |  |  |  |  |  |  |  |  |  |  |  |  |  |  |  |  |  |  |  |  |  |  |  |  |  |  |
| F3060 |  | Design Review 30% Part1 |  | 7d | 2008-09-29 A | 2008-10-08 A | AD1140, EJ000080 SS, F3600, EJ000090 SS, EJ000184 SS | 100% |  |  |  |  |  | F3060 | F3060 | 876 | 0D | 91 | 200 | 200 | 050 | AD | 3B | LND | C2 | E | L | ER33 | LUZ2 | E | LND |  |  |  |  |  |
| F4035 |  | 60% Design Review -downstream- |  | 7d | 2009-10-19 A | 2009-10-27 A | AD2230 FS+80d, A1KL1140 FF, A1CF0235 FS+12d, E3J0350 | 100% |  |  |  |  |  | F4035 | F4035 | 876 | 0D | 91 | 200 |  |  | E |  | LND | L2 | E | L | ER36 | LUZ2 | 2 | LND | 60% модель проекта, участок обработки продукта |  |  |  |  |
| IMS-E-000080 |  | 60% Design Review | level of effort | 317d | 2009-10-19 A | 2011-01-20 A | F4035 SS | 100% |  |  |  |  |  | IMS-E-000080 | IMS-E-000080 | 876 | 0D | 91 | 200 |  |  |  |  | LNI | L2 | E | L | ER36 | LUZ2 | 2 | IMS | 90% модель проекта, технологическое оборудование |  |  |  |  |
| F4030 |  | 60% Design Review -upstream- 11/12/13/51,55-56 |  | 12d | 2009-11-02 A | 2009-11-17 A | E3M1050 FF, E3J0250 FS+10d, E3J02D50, E3J0150, E3U1550, E3J04B50 FS+30d, E3M0850 FF, ER000160 FF, E3J02C50 FS+10d, P3J01AD1 FS+30d, E3J0350, A1CF0235 FS+12d, E3J04A50 FS+30d, E3J01A50, A1010110 FF, AD2230 FS+80d, A1KL1140 FF, F4035 FS+3d, ER000160 SS, E3J02B50 FS+10d | 100% |  |  |  |  |  | F4030 | F4030 | 876 | 0D | 91 | 200 |  |  | E |  | LEI | L2 | E | L | ER36 | LUZ2 | 2 | LND | 60% модель проекта, технологическое оборудование | 2DC8480 |  |  |  |
| F4040 |  | 60% Design Review -upstream- 15/16/17/52,54 |  | 15d | 2010-03-01 A | 2010-03-19 A | IMS-E-000080 FF, F4030 FS+55d, P3M01L1 FF | 100% |  |  |  |  |  | F4040 | F4040 | 876 | 0D | 91 | 200 |  |  | E |  | LEI | L2 | E | L | ER36 | LUZ2 | 2 | LND | 60% модель проекта, технологическое оборудование | 2DC8480 |  |  |  |
| F9250 |  | 90% Design Review -downstream part- |  | 10d | 2010-04-26 A | 2010-05-07 A | HPR30 FF, E3U0760 SS, F4030, E3U0750 FF, A1KL0030, F4035 FS+103d, EN000165 | 100% |  |  |  |  |  | F9250 | F9250 | 876 | 0D | 90 | 200 |  |  |  |  | LND | L2 | E | L | ER39 | LUZ2 | 3 | LND | 90% модель проекта, участок обработки продукта |  |  |  |  |
| IMS-E-000090 |  | 90% Design Review | level of effort | 189d | 2010-04-26 A | 2011-01-20 A | F9250 SS | 100% |  |  |  |  |  | IMS-E-000090 | IMS-E-000090 | 876 | 0D | 91 | 200 |  |  |  |  | LNI | L2 | E | L | ER39 | LUZ2 | 3 | IMS | 90% модель проекта, технологическое оборудование |  |  |  |  |
| F4460 |  | 90% Design Review -upstream part- 11/12/13/51-56 |  | 15d | 2010-06-21 A | 2010-07-09 A | E3U0767, P3S06D, E3M1060, E3J12B50, E3J0750, E3A02C50 FF, M3R120 FF, F4040 FS+41d, E3J04C50 FF, E3M0860, A1KL0030, F9250 FS+18d, F4030 FS+75d, F4035 FS+85d, E3J14B50 FF, E3U0667, IMS-E-000090 FF, E3J1850 FF, E3J02A50, P3S10D, HPR30 FF, IMS-E-000020 FS+25d | 100% |  |  |  |  |  | F4460 | F4460 | 876 | 0D | 91 | 200 |  |  |  |  | LEI | L2 | E | L | ER39 | LUZ2 | 3 | LND | 90% модель проекта, технологическое оборудование |  |  |  |  |
| F4462 |  | 90% Design Review -upstream part- 16/17 |  | 10d | 2010-09-06 A | 2010-09-17 A | F4460 FS+20d, F4040 FS+50d | 100% |  |  |  |  |  | F4462 | F4462 | 876 | 0D | 91 | 200 |  |  |  |  | LEI | L2 | E | L | ER39 | LUZ2 | 3 | LND | 90% модель проекта, технологическое оборудование |  |  |  |  |
| F4048 |  | 60% Design Review -upstream- 10 - PRU Section |  | 2d | 2010-09-20 A | 2010-09-21 A | IMS-E-000080 FF, F4040 FS+20d, F4462 SS+10d, ER10000 | 100% |  |  |  |  |  | F4048 | F4048 | 876 | 0D | 91 | 200 |  |  | E |  | LEI | L2 | E | L | ER36 | 1010 | 2 | LND | 60% модель проекта, технологическое оборудование | 2DC8480 |  |  |  |
| F4465 |  | 90% Design Review -upstream part- 10 |  | 2d | 2010-09-20 A | 2010-09-21 A | EL20020, F4048 FF, IMS-E-000090 FF | 100% |  |  |  |  |  | F4465 | F4465 | 876 | 0D | 91 | 200 |  |  |  |  | LEI | L2 | E | L | ER39 | LUZ2 | 3 | LND | 90% модель проекта, технологическое оборудование |  |  |  |  |
| F4045 |  | 60% Design Review -upstream- 14/53 - Flare Area |  | 3d | 2011-01-18 A | 2011-01-20 A | F4040, IMS-E-000080 FF, ER14000 FS+118d | 100% |  |  |  |  |  | F4045 | F4045 | 876 | 0D | 91 | 200 |  |  | E |  | LEI | L2 | E | L | ER36 | 1410 | 2 | LND | 60% модель проекта, технологическое оборудование |  |  |  |  |
| F4468 |  | 90% Design Review -upstream part- 14/53 |  | 3d | 2011-01-18 A | 2011-01-20 A | ER000195 FF, F4045 FF, EL20020, IMS-E-000090 FF, EP000195, EN000200, EN000175 FF | 100% |  |  |  |  |  | F4468 | F4468 | 876 | 0D | 91 | 200 |  |  |  |  | LEI | L2 | E | L | ER39 | LUZ2 | 3 | LND | 90% модель проекта, технологическое оборудование |  |  |  |  |
| F4050 |  | 60% Design Review -upstream- 18 - Chiller Unit Area |  | 1d | 2011-09-26 | 2011-09-26 | E3A02D50, ER18000, E3M1850, E3M1750 |  | 392.5d | 0d |  |  |  | F4045 | F4050 | 876 | 0D | 91 | 200 |  |  | E |  | LEI | L2 | E | L | ER36 | 1810 | 2 | LND | 60% модель проекта, технологическое оборудование |  |  |  |  |
| F4475 |  | 90% Design Review -upstream- 18 - Chiller Unit Area |  | 1d | 2011-10-26 | 2011-10-26 | F4050 FS+20d |  | 392.5d | 0d |  |  |  | F4045 | F4475 | 876 | 0D | 91 | 200 |  |  | E |  | LEI | L2 | E | L | ER39 | 1810 | 3 | LND | 60% модель проекта, технологическое оборудование |  |  |  |  |
|  | N | **N Structural Steel** |  |  | 2010-02-24 | 2011-01-31 |  |  |  |  |  |  |  |  |  |  |  |  |  |  |  |  |  |  |  |  |  |  |  |  |  |  |  |  |  |  |
| ETN00100 |  | Prep. Structural steel Turnover documentation |  | 236.5d | 2010-02-24 A | 2011-01-31 A | DE1000 | 100% |  |  | TKB-S [408 h] |  |  | ETN00100 | ETN00100 | 87B | 0D |  | 200 | 200 | 002 | E | 3B | LND | 1 | E | N | 0000 | LUZ2 | 00 | LND |  |  | 408,00 |  |  |
|  | H | **H HVAC** |  |  | 2009-05-25 | 2011-01-26 |  |  |  |  |  |  |  |  |  |  |  |  |  |  |  |  |  |  |  |  |  |  |  |  |  |  |  |  |  |  |
| E3H0115 |  | H01 HVAC - Final Input/Loads for HVAC Design | milestone | 0d | 2009-05-25 A | 2009-05-25 A | F4120 | 100% |  |  |  |  |  | E3H0115 | E3H0115 | 87C | 0D |  | 000 | 200 | 055 | E |  | LND | 0 | E | H | EH13 | LUZ2 | P | LND |  | H01 |  | H01 | DEV |
| E3H0110 |  | H01 HVAC - Inquiry Docs. (Prep BOQ) |  | 55d | 2009-06-02 A | 2009-08-17 A | E3H0115 | 100% |  |  |  |  |  | E3H0110 | E3H0110 | 87C | 0D |  | 000 | 200 | 055 | E |  | LND | 0 | E | H | EH13 | LUZ2 | P | LND |  | H01 |  | H01 | DEV |
| EH1000 |  | General Tasks & Coordinations DE Phase (HVAC) |  | 265d | 2009-12-01 A | 2010-12-17 A | DE1000 | 100% |  |  | TKB-H [7608 h] |  |  | EH1000 | EH1000 | 87C | 0D |  | 000 | 200 | 400 | P |  | LND | 0 | E | H | EH13 | LUZ2 | OTH | LND |  | H01 | 7608,00 | H01 | DEV |
| EH1010 |  | General - Contractor's Workshop Engin. - Review |  | 25d | 2010-12-21 A | 2011-01-26 A | P3H01D, EH30311010 | 100% |  |  | TKB-H [640 h] |  |  | EH1010 | EH1010 | 87C | 0D |  | 200 | 200 | 035 | E |  | LND |  | E | H | EH30 | LUZ2 | OTH | LND |  |  | 640,00 |  |  |
|  | U | **U Package Units** |  |  | 2008-11-10 | 2011-01-14 |  |  |  |  |  |  |  |  |  |  |  |  |  |  |  |  |  |  |  |  |  |  |  |  |  |  |  |  |  |  |
| E3U1040 |  | PU10 Convey. Syst. - 1st Review Vendor Dwgs |  | 55d | 2008-11-10 A | 2009-02-02 A | P3U10D FS+15d | 100% |  |  |  |  |  | E3U1040 | E3U1040 | 869 | 0D | DC | 200 | 200 | 400 | E | 3A | LND | C2 | E | U | EU15 | LUZ2 | 3 | LND |  | 2DC8990 |  | PU10 | DFA |
| E3U1530 |  | PU15 Reactor Seal Oil Pack -Techn. Eval./Bid Tab | milestone | 0d | 2008-11-29 A | 2008-11-29 A | E3U1515 SF, E3U1520 FF-7d | 100% |  |  |  |  |  | E3U1530 | E3U1530 | 869 | 0D |  | 200 | 200 | 055 | E |  | LND | 0 | E | U | EU94 | LUZ2 | 2 | LND |  | 2DC8910 |  | PU15 |  |
| E3U1050 |  | PU10 Convey. Syst. - Vendor dwgs approved | milestone | 0d | 2009-02-03 A | 2009-02-03 A | E3U1040 FF | 100% |  |  |  | 4,158,076.4 | 4,158,076.4 | E3U1050 | E3U1050 | 869 | 0D | DC | 200 | 200 | 400 | E |  | LND | C2 | E | U | EU15 | LUZ2 | 3 | LND |  | 2DC8990 |  | PU10 |  |
| E3U1060 |  | PU10 Convey. Syst. - 2nd Review Vendor Dwgs |  | 25d | 2009-02-04 A | 2009-03-10 A | E3U1050 FS+20d, P3U10D FS+45d | 100% |  |  |  |  |  | E3U1060 | E3U1060 | 869 | 0D | DC | 200 | 200 | 400 | E |  | LND | C2 | E | U | EU15 | LUZ2 | 3 | LND |  | 2DC8990 |  | PU10 |  |
| E3U1540 |  | PU15 Reactor Seal Oil Pack - 1st Review dwgs |  | 10d | 2009-09-21 A | 2009-10-02 A | P3U15D1 FF+30d | 100% |  |  | TAA [1600 h] |  |  | E3U1540 | E3U1540 | 869 | 0D |  | 200 | 200 | 055 | E |  | LND | 0 | E | U | EU95 | LUZ2 | 2 | LND |  | 2DC8910 | 1600,00 | PU15 |  |
| E3U1550 |  | PU15 Reactor Seal Oil P - Vendor dwgs approved | milestone | 0d | 2009-10-02 A | 2009-10-02 A | E3U1540 FF | 100% |  |  |  | 153,400 | 153,400 | E3U1550 | E3U1550 | 869 | 0D |  | 200 | 200 | 055 | E |  | LND | 0 | E | U | EU95 | LUZ2 | 2 | LND |  | 2DC8910 |  | PU15 | DFA |
| E3U1560 |  | PU15 Reactor Seal Oil Pack - 2nd Review dwgs |  | 188d | 2009-10-22 A | 2010-07-23 A | P3U15D1 FF+60d | 100% |  |  | TAA [1200 h] |  |  | E3U1560 | E3U1560 | 869 | 0D |  | 200 | 200 | 055 | E |  | LND | 0 | E | U | EU95 | LUZ2 | 3 | LND |  | 2DC8910 | 1200,00 | PU15 |  |
| E3U1240 |  | PU12 Propyl.Recov.Unit - 1st Review dwgs |  | 23d | 2010-02-17 A | 2010-03-19 A | P3U12D FS+40d | 100% |  |  | TAA [2400 h] |  |  | E3U1240 | E3U1240 | 869 | 0D |  | 200 | 200 | 055 | E |  | LND | 0 | E | U | EU95 | LUZ2 | 2 | LND |  | 2KB4240 | 2400,00 | PU12 |  |
| E3U1250 |  | PU12 Propyl.Recov.Unit - Vendor dwgs approved | milestone | 0d | 2010-03-19 A | 2010-03-19 A | E3U1240 FF | 100% |  |  |  | 1,358,661.4 | 1,358,661.4 | E3U1250 | E3U1250 | 869 | 0D |  | 200 | 200 | 055 | E |  | LND | 0 | E | U | EU95 | LUZ2 | 2 | LND |  | 2KB4240 |  | PU12 | DFA |
| E3U1260 |  | PU12 Propyl.Recov.Unit - 2nd Review dwgs / detailed arrangement drwgs |  | 71d | 2010-05-20 A | 2010-08-27 A | E3U1240 FS+40d | 100% |  |  | TAA [2000 h] |  |  | E3U1260 | E3U1260 | 869 | 0D |  | 200 | 200 | 055 | E |  | LND | 0 | E | U | EU95 | LUZ2 | 2 | LND |  | 2KB4240 | 2000,00 | PU12 |  |
| E3U0530 |  | PU05 Big Bag L. Station -Techn. Eval./Bid Tab | milestone | 0d | 2010-07-01 A | 2010-07-01 A | E3U0520 FF-6d, E3U0515 SF | 100% |  |  |  |  |  | E3U0530 | E3U0530 | 869 | 0D |  | 200 | 200 | 055 | E |  | LND | 0 | E | U | EU94 | LUZ2 | 2 | LND |  | 2DC9640 |  | PU05 |  |
| E3U1565 |  | PU15 Reactor Seal Oil Pack - Review Instrument Data Sheets / PLC/ JB |  | 35d | 2010-07-14 A | 2010-08-31 A | E3U1560 SS+180d | 100% |  |  |  |  |  | E3U1565 | E3U1565 | 869 | 0D |  | 200 | 200 | 055 | E |  | LND | 0 | E | U | EU95 | LUZ2 | 3 | LND |  | 2DC8910 |  | PU15 |  |
| E3U2265 |  | PU22 Vacuum System - Review Instrument Data Sheets / PLC / JB |  | 44d | 2010-07-15 A | 2010-09-14 A | E3U2260 SS+185d | 100% |  |  |  |  |  | E3U2265 | E3U2265 | 869 | 0D |  | 200 | 200 | 055 | E |  | LND | 0 | E | U | EU95 | LUZ2 | 3 | LND |  | 2DC9170 |  | PU22 |  |
| E3U1265 |  | PU12 Propyl.Recov.Unit - Review Instrument Data Sheets / Loop Folder / JB |  | 80d | 2010-08-20 A | 2010-12-10 A | P3U12L SS+120d, E3U1260 SS+65d | 100% |  |  |  |  |  | E3U1265 | E3U1265 | 869 | 0D |  | 200 | 200 | 055 | E |  | LND | 0 | E | U | EU95 | LUZ2 | 2 | LND |  | 2KB4240 |  | PU12 |  |
| E3U0540 |  | PU05 Big Bag L. Station - 1st Review dwgs |  | 27d | 2010-08-30 A | 2010-10-05 A | HEB50 FF, P3U05L SS+40d | 100% |  |  | TAA [400 h] |  |  | E3U0540 | E3U0540 | 869 | 0D |  | 200 | 200 | 055 | E |  | LND | 0 | E | U | EU95 | LUZ2 | 3 | LND |  | 2DC9640 | 400,00 | PU05 |  |
| E3U1070 |  | PU10 Convey. Syst. - Review Final Documentation ((incl. Instr. Data Sheets/PLC/JB) |  | 97d | 2010-08-30 A | 2011-01-14 A | E3U1060, P3U10L FS-40d | 100% |  |  | TAA [1600 h] |  |  | E3U1070 | E3U1070 | 869 | 0D | DC | 200 | 200 | 400 | E |  | LND | C2 | E | U | EU15 | LUZ2 | 3 | LND |  | 2DC8990 | 1600,00 | PU10 |  |
| E3U0550 |  | PU05 Big Bag L. Station - Vendor dwgs approved | milestone | 0d | 2010-10-05 A | 2010-10-05 A | E3U0540 FF | 100% |  |  |  | 21,835.2 | 21,835.2 | E3U0550 | E3U0550 | 869 | 0D |  | 200 | 200 | 055 | E |  | LND | 0 | E | U | EU95 | LUZ2 | 3 | LND |  | 2DC9640 |  | PU05 | DFA |
| E3U0560 |  | PU05 Big Bag L. Station - 2nd Review dwgs |  | 52d | 2010-11-01 A | 2011-01-14 A | E3U0550, P3U05L SS+95d | 100% |  |  | TAA [400 h] |  |  | E3U0560 | E3U0560 | 869 | 0D |  | 200 | 200 | 055 | E |  | LND | 0 | E | U | EU95 | LUZ2 | 3 | LND |  | 2DC9640 | 400,00 | PU05 |  |

Notes:
- F9250: P3 Activity Log Info: vor upstream
- E3U1050: Expenses: 900A 4158076
- E3U1550: Expenses: 900A 153400
- E3U1250: Expenses: 900A 1358661
- E3U0550: Expenses: 900A 21835.2

| ID | WBS | Activity | Type | Duration | Start | Finish | Predecessors | Complete | Resources | Cost | Actual cost | UDF_SAVE ACTID | UDF_SAVE ACT ID | Department | Type of Work | Constr. Area | Inquiry/Order No | PMT-Area | PMT-Schedule Org | PMT-Discipline | PMT-Phase | PMT-Respons. | Zeigen/n. Zeigen | WBS Phase | WBS Discipline | WBS Type of Work | WBS Objects | IMS | UPT | PMT-Doc. Type | TB26 Ressource Budget |
| --- | --- | --- | --- | --- | --- | --- | --- | --- | --- | --- | --- | --- | --- | --- | --- | --- | --- | --- | --- | --- | --- | --- | --- | --- | --- | --- | --- | --- | --- | --- | --- |
|  | B | **B Mechanical - Stationary Equipment** |  |  | 2008-09-04 | 2010-08-20 |  |  |  |  |  |  |  |  |  |  |  |  |  |  |  |  |  |  |  |  |  |  |  |  |  |
| E3A06A15 |  | A06A Electrical Heater - Prel.Bid for PMT review | milestone | 0d | 2008-09-04 A | 2008-09-04 A | E3A06A20 SS-3d | 100% |  |  |  | E3A06A15 | E3A06A15 | 869 | A06A | 0D | 2DC9080 | 200 | 200 | 055 | E | LND | 0 | E | B | EB24 | LUZ2 | 3 | LND |  |  |
| E3A1115 |  | A11 Unloading Arms - Prel.Bid for PMT review | milestone | 0d | 2008-09-15 A | 2008-09-15 A | E3A1120 SS-30d | 100% |  |  |  | E3A1115 | E3A1115 | 869 | A11 | 0D | 2KB4420 | 200 | 200 | 055 | E | LND | 0 | E | B | EB94 | LUZ2 | 3 | LND |  |  |
| E3A0115 |  | A01 Drums/Small Vessels- Prel.Bid for PMT review | milestone | 0d | 2008-10-29 A | 2008-10-29 A | E3A0120 SS-2d | 100% |  |  |  | E3A0115 | E3A0115 | 869 | A01 | 0D | 2DD8530 | 200 | 200 | 055 | E | LND | 0 | E | B | EB14 | LUZ2 | INS | LND |  |  |
| E3A0615 |  | A06 Start-Up Heater/Condenser - Prel.Bid for PMT review | milestone | 0d | 2008-10-29 A | 2008-10-29 A | E3A0620 SS-1d | 100% |  |  |  | E3A0615 | E3A0615 | 869 | A06 | 0D | 2DD8530 | 200 | 200 | 055 | E | LND | 0 | E | B | EB24 | LUZ2 | 3 | LND |  |  |
| E3A02A15 |  | A02A Large Drums - Prel.Bid for PMT review | milestone | 0d | 2008-11-26 A | 2008-11-26 A | E3A02A20 SS-2d | 100% |  |  |  | E3A02A15 | E3A02A15 | 869 | A02A | 0D | 2DC9450 | 200 | 200 | 055 | E | LND | 0 | E | B | EB14 | LUZ2 | 3 | LND |  |  |
| E3A1315 |  | A13 Scales - Prel.Bid for PMT review | milestone | 0d | 2008-12-19 A | 2008-12-19 A | E3A1320 SS-5d | 100% |  |  |  | E3A1315 | E3A1315 | 869 | A13 | 0D | 2DC9060 | 200 | 200 | 055 | E | LND | 0 | E | B | EB94 | LUZ2 | 3 | LND |  |  |
| E3A1205 |  | A12 Overhead Cranes - Inquiry for cost estimate |  | 18d | 2009-01-19 A | 2009-02-11 A | F1670 | 100% |  |  |  | E3A1205 | E3A1205 | 869 | A12 | 0D | 2KB4740 | 200 | 200 | 055 | E | LND | 0 | E | B | EB93 | LUZ2 | 3 | LND | DEV |  |
| E3A1320 |  | A13 Scales - Techn. Eval./PO Spec |  | 301d | 2009-02-18 A | 2010-04-30 A | P3A13B FS+185d, HEB20 FF | 100% | TAA [600 h] |  |  | E3A1320 | E3A1320 | 869 | A13 | 0D | 2DC9060 | 200 | 200 | 055 | E | LND | 0 | E | B | EB94 | LUZ2 | 2 | LND |  | 600,00 |
| E3A02B15 |  | A02B Polymer W.Basket - Prel.Bid for PMT review | milestone | 0d | 2009-02-25 A | 2009-02-25 A | E3A02B20 SS-3d | 100% |  |  |  | E3A02B15 | E3A02B15 | 869 | A02B | 0D | 2DC9840 | 200 | 200 | 055 | E | LND | 0 | E | B | EB14 | LUZ2 | 3 | LND |  |  |
| E3A0315 |  | A03 Catalyst Drum Roll - Prel.Bid for PMT review | milestone | 0d | 2009-04-01 A | 2009-04-01 A | E3A0320 SS-20d | 100% |  |  |  | E3A0315 | E3A0315 | 869 | A03 | 0D | 2DC9630 | 200 | 200 | 055 | E | LND | 0 | E | B | EB94 | LUZ2 | 3 | LND |  |  |
| E3A1210 |  | A12 Overhead Cranes - Inquiry Spec. |  | 15d | 2009-07-13 A | 2009-07-31 A | F1670 SS+220d | 100% |  |  |  | E3A1210 | E3A1210 | 869 | A12 | 0D | 2KB4740 | 200 | 200 | 055 | E | LND | 0 | E | B | EB93 | LUZ2 | 3 | LND | DEV |  |
| E3A1330 |  | A13 Scales -Techn. Eval./Bid Tab F | milestone | 0d | 2010-02-05 A | 2010-02-05 A | E3A1320 FF-10d, E3A1315 SF | 100% |  |  |  | E3A1330 | E3A1330 | 869 | A13 | 0D | 2DC9060 | 200 | 200 | 055 | E | LND | 0 | E | B | EB94 | LUZ2 | 2 | LND |  |  |
| E3A1340 |  | A13 Scales - 1st Review dwgs |  | 21d | 2010-06-21 A | 2010-07-19 A | P3A13D FS+34d, HEB50 FF | 100% | TAA [800 h] |  |  | E3A1340 | E3A1340 | 869 | A13 | 0D | 2DC9060 | 200 | 200 | 055 | E | LND | 0 | E | B | EB95 | LUZ2 | 3 | LND |  | 800,00 |
| E3A1350 |  | A13 Scales - Vendor dwgs approved | milestone | 0d | 2010-07-19 A | 2010-07-19 A | E3A1340 FF | 100% |  | 47,443.2 | 47,443.2 | E3A1350 | E3A1350 | 869 | A13 | 0D | 2DC9060 | 200 | 200 | 055 | E | LND | 0 | E | B | EB95 | LUZ2 | 3 | LND | DFA |  |
| E3A1360 |  | A13 Scales - 2nd Review dwgs |  | 18d | 2010-07-28 A | 2010-08-20 A | E3A1350, P3A13D FS+66d | 100% | TAA [600 h] |  |  | E3A1360 | E3A1360 | 869 | A13 | 0D | 2DC9060 | 200 | 200 | 055 | E | LND | 0 | E | B | EB95 | LUZ2 | 3 | LND |  | 600,00 |
|  | E | **E Electrical** |  |  | 2008-11-26 | 2011-06-23 |  |  |  |  |  |  |  |  |  |  |  |  |  |  |  |  |  |  |  |  |  |  |  |  |  |
| EE900070 |  | CA00 General -Layout Plan Earthing+Lightning Sys |  | 84d | 2008-11-26 A | 2009-03-30 A | AD1710 FF | 100% |  |  |  | EE900070 | EE900070 | 874 |  | 0D |  |  |  |  | E | LND |  | E | E | EE90 | LUZ2 | E | LND |  |  |
| E3E1105 |  | Earthing - Preparation BOQ f. OBCE |  | 20d | 2009-01-05 A | 2009-01-30 A | EE000040 FF | 100% |  |  |  | E3E1105 | E3E1105 | 87E | E11 | 0D | E11 | 200 | 200 | 055 | E | LND | 0 | E | E | EE28 | LUZ2 | E | LND | DEV |  |
| E3E1405 |  | E14 Local Switches/PushBS - Preparation BOQ f. OBCE |  | 20d | 2009-01-05 A | 2009-01-30 A | EE000040 FF | 100% |  |  |  | E3E1405 | E3E1405 | 87E | E14 | 0D | 2EB6120 | 200 | 200 | 055 | E | LND | 0 | E | E | EE36 | LUZ2 | E | LND | DEV |  |
| E3E15B05 |  | E15B Elec. LV Power Cable - Preparation BOQ f. OBCE |  | 20d | 2009-01-05 A | 2009-01-30 A | EE000040 FF | 100% |  |  |  | E3E15B05 | E3E15B05 | 87D | E15B | 0D | 2EB6200 | 200 | 200 | 055 | E | LND | 0 | E | E | EE30 | LUZ2 | E | LND | DEV |  |
| E3E1605 |  | E16 El.Cable Tray Syst. - Preparation BOQ f. OBCE |  | 20d | 2009-01-05 A | 2009-01-30 A | EE000040 FF, AD1940 | 100% |  |  |  | E3E1605 | E3E1605 | 87D | E16 | 0D | E16 | 200 | 200 | 055 | E | LND | 0 | E | E | EE29 | LUZ2 | E | LND | DEV |  |
| E3E0905 |  | Light./Power Sockets - Preparation BOQ f. OBCE |  | 15d | 2009-01-12 A | 2009-01-30 A | EE000040 FF | 100% |  |  |  | E3E0905 | E3E0905 | 87E | E09 | 0D | E09 | 200 | 200 | 055 | E | LND | 0 | E | E | EE33 | LUZ2 | P | LND | DEV |  |
| E3E15C05 |  | E15C Cable Glands - Preparation BOQ f. OBCE |  | 15d | 2009-01-12 A | 2009-01-30 A | EE000040 FF | 100% |  |  |  | E3E15C05 | E3E15C05 | 87E | E15C | 0D | 2EB6210 | 200 | 200 | 055 | E | LND | 0 | E | E | EE37 | LUZ2 | E | LND | DEV |  |
| EE300020 |  | Motor Data Sheets |  | 495d | 2009-02-02 A | 2011-01-18 A | E3M0660 FF, E3M0560 FF+12d, E3M0760 FF, E3M0260 FF, E3M0460 FF, E3M0160 FF, E3M0360 FF | 100% | TAE [960 h] |  |  | EE300020 | EE300020 | 874 |  | 0D |  |  |  |  | E | LND |  | E | E | EE31 | LUZ2 | E | LND |  | 960,00 |
| EE500080 |  | Design calc. critical cables (MV cables-FA) |  | 70d | 2009-05-25 A | 2009-08-31 A | EE900070 FF | 100% |  |  |  | EE500080 | EE500080 | 874 |  | 0D |  |  |  |  | E | LND |  | E | E | EE50 | LUZ2 | E | LND |  |  |
| EE300170 |  | Electrical Consumer List - w/o Lift's (to provide by Constr.Company) |  | 395d | 2009-07-27 A | 2011-02-15 A | EE000150, EE000220 SS | 100% | TAE [3456 h] |  |  | EE300170 | EE300170 | 874 |  | 0D |  |  |  |  | E | LND |  | E | E | EE31 | LUZ2 | E | LND |  | 3456,00 |
| EE500130 |  | Cable List |  | 26d | 2009-07-27 A | 2009-08-31 A | EE500080 FF | 100% |  |  |  | EE500130 | EE500130 | 874 |  | 0D |  |  |  |  | E | LND |  | E | E | EE50 | LUZ2 | E | LND |  |  |
| E3E1135 |  | Earthing - Preparation Final BOQ |  | 15d | 2009-09-01 A | 2009-09-21 A | E3E1105 FS+120d | 100% |  |  |  | E3E1135 | E3E1135 | 87E | E11 | 0D | E11 | 200 | 200 | 055 | E | LND | 0 | E | E | EE28 | LUZ2 | E | LND | DEV |  |
| EE500140 |  | Cable List final w/o Lifts |  | 379d | 2009-09-01 A | 2011-03-01 A | EE500130 | 100% |  |  |  | EE500140 | EE500140 | 874 |  | 0D |  |  |  |  | E | LND |  | E | E | EE50 | LUZ2 | E | LND |  |  |
| E3E1635 |  | E16 El.Cable Tray Syst. - Preparation BOQ for Inquiry |  | 125d | 2009-09-07 A | 2010-03-05 A | E3E1605 FS+150d | 100% |  |  |  | E3E1635 | E3E1635 | 87D | E16 | 0D | E16 | 200 | 200 | 055 | E | LND | 0 | E | E | EE29 | LUZ2 | E | LND | DEV |  |
| E3E1305 |  | E13 CCTV System - Feed Phase (Client) |  | 246d | 2009-09-28 A | 2010-09-17 A |  | 100% |  |  |  | E3E1305 | E3E1305 | 87D | E13 | 0D | 2EB6080 | 200 | 200 | 055 | E | PMT | 0 | E | E | EE43 | LUZ2 | E | PMT | DEV |  |
| EE300090 |  | Start-up Calculation MV-Motors |  | 125d | 2009-09-28 A | 2010-03-26 A | EE300020 SS | 100% |  |  |  | EE300090 | EE300090 | 874 |  | 0D |  |  |  |  | E | LND |  | E | E | EE31 | LUZ2 | E | LND |  |  |
| EE000140 |  | Ilumination level calculation |  | 167d | 2009-10-02 A | 2010-06-04 A | AD2230 FS+20d, F4030 FF+50d | 100% | TAE [1280 h] |  |  | EE000140 | EE000140 | 874 |  | 0D |  |  |  |  | E | LEI |  | E | E | EE70 | LUZ2 | E | LND |  | 1280,00 |
| E3E1204 |  | Fire-/Gas Detection S. - Feed Phase finalized - confirmed by Client | milestone | 0d | 2009-11-25 A | 2009-11-25 A |  | 100% |  |  |  | E3E1204 | E3E1204 | 87D | E12 | 0D | E12 | 200 | 200 | 055 | E | UIO | C6 | E | E | EE40 | LUZ2 | E | PMT | DEV |  |
| E3E1304 |  | E13 CCTV System - Feed Phase finalized - confirmed by Client | milestone | 0d | 2009-11-25 A | 2009-11-25 A | DE1000 SF | 100% |  |  |  | E3E1304 | E3E1304 | 87D | E13 | 0D | 2EB6080 | 200 | 200 | 055 | E | PMT | 0 | E | E | EE43 | LUZ2 | E | PMT | DEV |  |
| EE360260 |  | Layout plans Electrical Equipment |  | 71d | 2009-12-07 A | 2010-03-19 A | F4040 FF+10d, F4030 FS+10d | 100% | TAE [3200 h] |  |  | EE360260 | EE360260 | 874 |  | 0D |  |  |  |  | E | LEI |  | E | E | EE46 | LUZ2 | E | LND |  | 3200,00 |
| EE000180 |  | Start Layout Plan Lighting and Socket System | milestone | 0d | 2010-01-22 A | 2010-01-22 A | F4030, EE000140 FS-30d | 100% |  |  |  | EE000180 | EE000180 | 874 |  | 0D |  |  |  |  | E | LEI |  | E | E | EE76 | LUZ2 | E | LND |  |  |
| E3E1610 |  | E16 El.Cable Tray Syst. - Inquiry Spec. |  | 15d | 2010-02-15 A | 2010-03-05 A | E3E1635 FF | 100% |  |  |  | E3E1610 | E3E1610 | 87D | E16 | 0D | E16 | 200 | 200 | 055 | E | LND | 0 | E | E | EE29 | LUZ2 | E | LND | DEV |  |
| E3E1310 |  | E13 CCTV System - Inquiry Spec |  | 19d | 2010-03-08 A | 2010-04-01 A | E3E1305 FS+10d | 100% | TAE [1600 h] |  |  | E3E1310 | E3E1310 | 87D | E13 | 0D | 2EB6080 | 200 | 200 | 055 | E | PMT | 0 | E | E | EE43 | LUZ2 | E | LND | DEV | 1600,00 |
| E3E15A10 |  | E15A Elec. MV Power Cable - Inquiry Spec. |  | 16d | 2010-03-29 A | 2010-04-21 A | F1960 SS, E3E0710 SS+10d, AD1780, EE500080 SS+9d, F4030 FS+60d | 100% | TAE [320 h] |  |  | E3E15A10 | E3E15A10 | 87D | E15A | 0D | 2EB6110 | 200 | 200 | 055 | E | LND | 0 | E | E | EE26 | LUZ2 | E | LND | DEV | 320,00 |
| E3E1410 |  | E14 Local Switches/PushBS - Techn. Spec. |  | 24d | 2010-04-06 A | 2010-05-07 A | E3E1405 FS+25d | 100% | TAE [320 h] |  |  | E3E1410 | E3E1410 | 87E | E14 | 0D | 2EB6120 | 200 | 200 | 055 | E | LND | 0 | E | E | EE36 | LUZ2 | E | LND | DEV | 320,00 |
| E3E15B10 |  | E15B Elec. LV Power Cable - Inquiry Spec. |  | 15d | 2010-04-26 A | 2010-05-17 A | E3E15A10 FS+15d, F4030 | 100% | TAE [320 h] |  |  | E3E15B10 | E3E15B10 | 87D | E15B | 0D | 2EB6200 | 200 | 200 | 055 | E | LND | 0 | E | E | EE30 | LUZ2 | E | LND | DEV | 320,00 |
| E3E15C10 |  | E15C Cable Glands - Inquiry Spec. |  | 10d | 2010-05-14 A | 2010-05-28 A | F4030, E3E15C05, E3E15A10 FS+15d | 100% | TAE [184 h] |  |  | E3E15C10 | E3E15C10 | 87E | E15C | 0D | 2EB6210 | 200 | 200 | 055 | E | LND | 0 | E | E | EE37 | LUZ2 | E | LND | DEV | 184,00 |
| E3E1220 |  | Fire-/Gas Detection S. - Prep. of Spec/Detail Phase Linde Scope |  | 32d | 2010-05-17 A | 2010-06-30 A |  | 100% | TAE [320 h] |  |  | E3E1220 | E3E1220 | 87D | E12 | 0D | E12 | 200 | 200 | 055 | E | PMT | C6 | E | E | EE40 | LUZ2 | E | LND |  | 320,00 |
| E3E1320 |  | E13 CCTV System - Techn. Eval./PO Spec |  | 280d | 2010-05-25 A | 2011-06-23 A | P3E13B FS+25d | 100% | TAE [1600 h] |  |  | E3E1320 | E3E1320 | 87D | E13 | 0D | 2EB6080 | 200 | 200 | 055 | E | PMT | 0 | E | E | EE43 | LUZ2 | E | LND |  | 1600,00 |
| E3E15A20 |  | E15A Elec. MV Power Cable - Techn. Eval./PO Spec |  | 206d | 2010-05-28 A | 2011-03-16 A | P3E15AB FS+19d | 100% | TAE [320 h] |  |  | E3E15A20 | E3E15A20 | 87D | E15A | 0D | 2EB6110 | 200 | 200 | 055 | E | LND | 0 | E | E | EE26 | LUZ2 | E | LND |  | 320,00 |
| E3E1620 |  | E16 El.Cable Tray Syst. - PO Spec. |  | 117d | 2010-05-31 A | 2010-11-09 A | P3E16B FS+52d | 100% |  |  |  | E3E1620 | E3E1620 | 87D | E16 | 0D | E16 | 200 | 200 | 055 | E | LND | 0 | E | E | EE29 | LUZ2 | E | LND | DEV |  |
| E3E1210 |  | Fire-/Gas Detection S. - Inquiry Spec Linde Scope |  | 22d | 2010-06-01 A | 2010-06-30 A | F2000, F3650 | 100% | TAE [320 h] |  |  | E3E1210 | E3E1210 | 87D | E12 | 0D | E12 | 200 | 200 | 055 | E | PMT | C6 | E | E | EE40 | LUZ2 | E | LND | DEV | 320,00 |
| E3E1640 |  | E16 El.Cable Tray Syst. - Preparation Final BOQ |  | 102d | 2010-06-21 A | 2010-11-09 A | EE46130110 FF, E3E1635, E3E1620 FF, EE46540110 FF+10d, EE46120110 FF, EE46510210 FF+20d, EE46171010 FF, EE46111010 FF, EE46540210 FF+10d, EE46161010 FF | 100% |  |  |  | E3E1640 | E3E1640 | 87D | E16 | 0D | E16 | 200 | 200 | 055 | E | LND | 0 | E | E | EE29 | LUZ2 | E | LND | DEV |  |
| E3E1420 |  | E14 Local Switches/PushBS - Techn. Eval./PO Spec (E&I SUB) |  | 113d | 2010-07-09 A | 2010-12-15 A | P3E14B FS+40d | 100% | TAE [320 h] |  |  | E3E1420 | E3E1420 | 87E | E14 | 0D | 2EB6120 | 200 | 200 | 055 | E | CC | 0 | E | E | EE36 | LUZ2 | E | LND |  | 320,00 |
| E3E15B20 |  | E15B Elec. LV Power Cable - Techn. Eval./PO Spec |  | 197d | 2010-07-14 A | 2011-04-19 A | P3E15BB FS+35d | 100% | TAE [320 h] |  |  | E3E15B20 | E3E15B20 | 87D | E15B | 0D | 2EB6200 | 200 | 200 | 055 | E | LND | 0 | E | E | EE30 | LUZ2 | E | LND |  | 320,00 |
| E3E15C20 |  | E15C Cable Glands - Techn. Eval./PO Spec (E&I SUB) |  | 196d | 2010-07-15 A | 2011-04-19 A | P3E15CB FS+20d | 100% | TAE [192 h] |  |  | E3E15C20 | E3E15C20 | 87E | E15C | 0D | 2EB6210 | 200 | 200 | 055 | E | LND | 0 | E | E | EE37 | LUZ2 | E | LND |  | 192,00 |
| E3E1920 |  | E19 Heat Tracing Syst. - PO Spec |  | 94d | 2010-07-21 A | 2010-11-30 A | P3E19B FS+20d | 100% | TAE [2032 h] |  |  | E3E1920 | E3E1920 | 87D | E19 | 0D | 2EB5180 | 200 | 200 | 055 | E | LND | 0 | E | E | EE39 | LUZ2 | E | LND |  | 2032,00 |
| E3E1250 |  | Fire-/Gas Detection S. - prior prel. Vendor dwgs approved |  | 29d | 2010-08-23 A | 2010-09-30 A |  | 100% | TAE [320 h] |  |  | E3E1250 | E3E1250 | 87D | E12 | 0D | E12 | 200 | 200 | 400 | E | PMT | C6 | E | E | EE40 | LUZ2 | E | LND |  | 320,00 |
| E3E1350 |  | E13 CCTV System - prior prel. Vendor dwgs appr. |  | 104d | 2010-08-23 A | 2011-01-18 A | P3E13C SS | 100% | TAE [1600 h] |  |  | E3E1350 | E3E1350 | 87D | E13 | 0D | 2EB6080 | 200 | 200 | 400 | E | PMT | 0 | E | E | EE43 | LUZ2 | E | LND |  | 1600,00 |
| E3E0935 |  | Light./Power Sockets - Preparation Final BOQ |  | 62d | 2010-08-30 A | 2010-11-24 A | EE763110 SS+20d, E3E0905 FS+200d, EE761300 FF, EE761110 FF, EE765101 FF+32d, EE761600 FF, EE761200 FF, EE765102 FF | 100% |  |  |  | E3E0935 | E3E0935 | 87E | E09 | 0D | E09 | 200 | 200 | 055 | E | LND | 0 | E | E | EE33 | LUZ2 | E | LND | DEV |  |
| E3E1950 |  | E19 Heat Tracing Syst. - Vendor dwgs approved | milestone | 0d | 2011-02-24 A | 2011-02-24 A | P3E19D FF+60d | 100% |  |  |  | E3E1950 | E3E1950 | 87D | E19 | 0D | 2EB5180 | 200 | 200 | 400 | E | LEI | 0 | E | E | EE39 | LUZ2 | E | LND |  |  |

Notes:
- E3A1350: Expenses: 900A 47443.2
- E3E1250: Expenses: 900A 0
- E3E1350: Expenses: 900A 0
- E3E1950: Expenses: 900A 0

| ID | WBS | Activity | Type | Duration | Start | Finish | Predecessors | Complete | Resources | UDF_SAVE ACTID | UDF_SAVE ACT ID | Department | Type of Work | Constr. Area | Pro Unit/DocCode | Inquiry/Order No | PMT-Area | PMT-Schedule Org | PMT-Discipline | PMT-Phase | PMT-Doc. Type | PMT-Respons. | Zeigen/n. Zeigen | WBS Phase | WBS Discipline | WBS Type of Work | WBS Objects | IMS | UPT | PMT-Stage | TB26 Ressource Budget |
| --- | --- | --- | --- | --- | --- | --- | --- | --- | --- | --- | --- | --- | --- | --- | --- | --- | --- | --- | --- | --- | --- | --- | --- | --- | --- | --- | --- | --- | --- | --- | --- |
|  | J | **J Instrumentation** |  |  | 2008-04-07 | 2011-09-20 |  |  |  |  |  |  |  |  |  |  |  |  |  |  |  |  |  |  |  |  |  |  |  |  |  |
| E3J04C10 |  | J04C Orifice/Venturi T. - Inquiry Spec. |  | 7d | 2008-04-07 A | 2008-04-15 A | F2570 SS | 100% |  | E3J04C10 | E3J04C10 | 86B | J04C | 0D | 999 | 2JD7320 | 200 | 200 | 055 | E | DEV | LND | 0 | E | J | EJ33 | LUZ2 | PI | LND |  |  |
| E3J0315 |  | J03 Nuclear Level Meas.- Prel.Bid for PMT review | milestone | 0d | 2008-05-14 A | 2008-05-14 A | E3J0320 SS-10d | 100% |  | E3J0315 | E3J0315 | 86B | J03 | 0D | 999 | 2JD7540 | 200 | 200 | 055 | E |  | LND | 0 | E | J | EJ34 | LUZ2 | PI | LND |  |  |
| E3J04A15 |  | J04A Coriolis Mass Flow- Prel.Bid for PMT review | milestone | 0d | 2008-06-20 A | 2008-06-20 A | E3J04A20 SS-10d | 100% |  | E3J04A15 | E3J04A15 | 86B | J04A | 0D | 999 | 2JD7280 | 200 | 200 | 055 | E |  | LND | 0 | E | J | EJ34 | LUZ2 | PI | LND |  |  |
| E3J04B15 |  | J04B Vortex Flowmeter - Prel.Bid for PMT review | milestone | 0d | 2008-06-20 A | 2008-06-20 A | E3J04B20 SS-10d | 100% |  | E3J04B15 | E3J04B15 | 86B | J04B | 0D | 999 | 2JD9260 | 200 | 200 | 055 | E |  | LND | 0 | E | J | EJ34 | LUZ2 | PI | LND |  |  |
| E3J0215 |  | J02 Control Valves - Prel.Bid for PMT review | milestone | 0d | 2008-08-20 A | 2008-08-20 A | E3J0220 SS-15d | 100% |  | E3J0215 | E3J0215 | 86B | J02 | 0D | 999 | 2AJ3030 | 200 | 200 | 055 | E |  | LND | 0 | E | J | EJ34 | LUZ2 | OTH | LND |  |  |
| E3J02B15 |  | J02B Knife Valves - Prel.Bid for PMT review | milestone | 0d | 2008-08-20 A | 2008-08-20 A | E3J02B20 SS-15d | 100% |  | E3J02B15 | E3J02B15 | 86B | J02B | 0D | 999 | 2AJ3000 | 200 | 200 | 055 | E |  | LND | 0 | E | J | EJ34 | LUZ2 | PI | LND |  |  |
| E3J02C15 |  | J02C Butterfly Valves - Prel.Bid for PMT review | milestone | 0d | 2008-08-20 A | 2008-08-20 A | E3J02C20 SS-15d | 100% |  | E3J02C15 | E3J02C15 | 86B | J02C | 0D | 999 | 2AJ3090 | 200 | 200 | 055 | E |  | LND | 0 | E | J | EJ34 | LUZ2 | PI | LND |  |  |
| E3J02D15 |  | J02D ON/OFF Plug Valves- Prel.Bid for PMT review | milestone | 0d | 2008-08-20 A | 2008-08-20 A | E3J02D20 SS-20d | 100% |  | E3J02D15 | E3J02D15 | 86B | J02D | 0D | 999 | 2AJ3020 | 200 | 200 | 055 | E |  | LND | 0 | E | J | EJ34 | LUZ2 | PI | LND |  |  |
| E3J01A15 |  | J01A Ball Valves - Prel.Bid for PMT review | milestone | 0d | 2008-08-28 A | 2008-08-28 A | E3J01A20 SS-5d | 100% |  | E3J01A15 | E3J01A15 | 86B | J01A | 0D | 999 | 2AJ2610 | 200 | 200 | 055 | E |  | LND | 0 | E | J | EJ34 | LUZ2 | OTH | LND |  |  |
| E3J0115 |  | J01 Ball Valves PDS - Prel.Bid for PMT review | milestone | 0d | 2008-09-02 A | 2008-09-02 A | E3J0120 SS-15d | 100% |  | E3J0115 | E3J0115 | 86B | J01 | 0D | 999 | 2AJ2620 | 200 | 200 | 055 | E |  | LND | 0 | E | J | EJ34 | LUZ2 | OTH | LND |  |  |
| E3J02B20 |  | J02B Knife Valves - Techn. Eval./PO Spec |  | 184d | 2008-09-11 A | 2009-06-12 A | P3J02BB FS+114d | 100% |  | E3J02B20 | E3J02B20 | 86B | J02B | 0D | 999 | 2AJ3000 | 200 | 200 | 055 | E |  | LND | 0 | E | J | EJ34 | LUZ2 | PI | LND |  |  |
| HEJ20LE |  | Techn. Eval./PO Spec's Eqpt (LINDE) | level of effort | 488d | 2008-09-11 A | 2010-08-25 A | E3J02D20 SS, E3J04B20 SS, E3J04A20 SS, E3J02B20 SS, E3J0220 SS, E3J01A20 SS, E3J02C20 SS, E3J0120 SS | 100% |  | HEJ20LE | HEJ20LE | 86A |  | 0D | 999 |  | 200 | 200 | 070 | AD |  | LND | L2 | E | J | EJ00 | LUZ2 | I | LND | 3A |  |
| E3J0120 |  | J01 Ball Valves PDS - Techn. Eval./PO Spec |  | 174d | 2008-09-25 A | 2009-06-12 A | AD1870 FF, P3J01B FS+120d, F4200 FF | 100% |  | E3J0120 | E3J0120 | 86B | J01 | 0D | 999 | 2AJ2620 | 200 | 200 | 055 | E |  | LND | 0 | E | J | EJ34 | LUZ2 | OTH | LND |  |  |
| E3J04A20 |  | J04A Coriolis Mass Flowm. - Techn. Eval./PO Spec |  | 177d | 2008-09-26 A | 2009-06-18 A | P3J04AB FS+120d | 100% |  | E3J04A20 | E3J04A20 | 86B | J04A | 0D | 999 | 2JD7280 | 200 | 200 | 055 | E |  | LND | 0 | E | J | EJ34 | LUZ2 | PI | LND |  |  |
| E3J04B20 |  | J04B Vortex Flowmeter - Techn. Eval./PO Spec |  | 173d | 2008-09-26 A | 2009-06-12 A | P3J04BB FS+120d | 100% |  | E3J04B20 | E3J04B20 | 86B | J04B | 0D | 999 | 2JD9260 | 200 | 200 | 055 | E |  | LND | 0 | E | J | EJ34 | LUZ2 | PI | LND |  |  |
| E3J02C20 |  | J02C Butterfly V. on/off - Techn. Eval./PO Spec |  | 161d | 2008-10-01 A | 2009-05-29 A | P3J02CB FS+105d | 100% |  | E3J02C20 | E3J02C20 | 86B | J02C | 0D | 999 | 2AJ3090 | 200 | 200 | 055 | E |  | LND | 0 | E | J | EJ34 | LUZ2 | PI | LND |  |  |
| E3J1810 |  | J18 Weighing for Vessels - Inquiry Spec. |  | 7d | 2008-10-01 A | 2008-10-10 A | F2570 FS+70d | 100% |  | E3J1810 | E3J1810 | 86B | J18 | 0D | 999 | J18 | 200 | 200 | 055 | E | DEV | LND | 0 | E | J | EJ33 | LUZ2 | I | LND |  |  |
| A1EJ0020 |  | Instrum. Function Engineering (1st Issue) |  | 445d | 2008-10-27 A | 2010-08-09 A | AD1830, E3J0520 FF | 100% |  | A1EJ0020 | A1EJ0020 | 86A |  | 0D | 999 |  | 200 |  |  | E |  | LND |  | E | J | EJ00 | LUZ2 | I | LND |  |  |
| E3J02B30 |  | J02B Knife Valves -Techn. Eval./Bid Tab | milestone | 0d | 2008-10-28 A | 2008-10-28 A | E3J02B15 SF, E3J02B20 FF-6d | 100% |  | E3J02B30 | E3J02B30 | 86B | J02B | 0D | 999 | 2AJ3000 | 200 | 200 | 055 | E |  | LND | 0 | E | J | EJ34 | LUZ2 | PI | LND |  |  |
| E3J12A10 |  | J12A Radar Level M. - Inquiry Spec. |  | 8d | 2008-11-17 A | 2008-11-27 A | F2570 SS+120d | 100% |  | E3J12A10 | E3J12A10 | 86B | J12A | 0D | 999 | 2JD8440 | 200 | 200 | 055 | E | DEV | LND | 0 | E | J | EJ33 | LUZ2 | I | LND |  |  |
| A1EJ0050 |  | Prel. Spec. f. Instruments (Typicals,Valves) |  | 15d | 2008-11-24 A | 2008-12-12 A | E3J0120 SS, E3J01A20 SS | 100% |  | A1EJ0050 | A1EJ0050 | 86A |  | 0D | 999 |  | 200 |  |  | E |  | LND |  | E | J | EJ00 | LUZ2 | I | LND |  |  |
| E3J0715 |  | J07 Analyser System - Prel.Bid for PMT review | milestone | 0d | 2008-11-24 A | 2008-11-24 A | E3J0720 SS-7d | 100% |  | E3J0715 | E3J0715 | 86B | J07 | 0D | 999 | 2JD7560 | 200 | 200 | 055 | E |  | LND | 0 | E | J | EJ34 | LUZ2 | I | LND |  |  |
| A1EJ0080 |  | Developm. Typicals Hook-up's/Loop's to LEI |  | 80d | 2008-12-03 A | 2009-03-31 A |  | 100% |  | A1EJ0080 | A1EJ0080 | 86A |  | 0D | 999 |  | 200 |  |  | E |  | LND |  | E | J | EJ00 | LUZ2 | I | LND |  |  |
| E3J06F10 |  | J06F PLC Network - Inquiry Spec. (prel.) |  | 15d | 2008-12-15 A | 2009-01-09 A | F2600 FS+80d | 100% |  | E3J06F10 | E3J06F10 | 86C | J06F | 0D | 999 | 2JD8450 | 200 | 200 | 055 | E | DEV | LND | 0 | E | J | EJ23 | LUZ2 | I | LND |  |  |
| E3J0720 |  | J07 Analyser System - Techn. Eval./PO Spec |  | 260d | 2008-12-17 A | 2010-01-05 A | P3J07B FS+151d, F4200 FF, F3770 | 100% | TAP [3360 h] | E3J0720 | E3J0720 | 86B | J07 | 0D | 999 | 2JD7560 | 200 | 200 | 055 | E |  | LND | 0 | E | J | EJ34 | LUZ2 | I | LND |  | 3360,00 |
| E3J1815 |  | J18 Weighing for Vessel- Prel.Bid for PMT review | milestone | 0d | 2008-12-19 A | 2008-12-19 A | E3J1820 SS-2d | 100% |  | E3J1815 | E3J1815 | 86B | J18 | 0D | 999 | J18 | 200 | 200 | 055 | E |  | LND | 0 | E | J | EJ34 | LUZ2 | I | LND |  |  |
| E3J0130 |  | J01 Ball Valves PDS -Techn. Eval./Bid Tab | milestone | 0d | 2008-12-20 A | 2008-12-20 A | E3J0115 SF, E3J0120 FF-40d | 100% |  | E3J0130 | E3J0130 | 86B | J01 | 0D | 999 | 2AJ2620 | 200 | 200 | 055 | E |  | LND | 0 | E | J | EJ34 | LUZ2 | OTH | LND |  |  |
| E3J04C15 |  | J04C Orifice/Venturi T.- Prel.Bid for PMT review | milestone | 0d | 2008-12-23 A | 2008-12-23 A | E3J04C20 SS-30d | 100% |  | E3J04C15 | E3J04C15 | 86B | J04C | 0D | 999 | 2JD7320 | 200 | 200 | 055 | E |  | LND | 0 | E | J | EJ34 | LUZ2 | PI | LND |  |  |
| A1EJ0915 |  | Eng. Process Control Equipment |  | 433d | 2009-01-02 A | 2010-09-20 A | A1EJ0020 FF+30d, IMS-E-000210 FF | 100% |  | A1EJ0915 | A1EJ0915 | 86A |  | 0D | 999 |  | 200 |  |  | E |  | LND |  | E | J | EJ00 | LUZ2 | I | LND |  |  |
| HEJ12 |  | Final Loads for Civil / StrSteel | level of effort | 15d | 2009-01-05 A | 2009-01-23 A | EJ46510308 SS, EJ46312008 SS, EJ46161008 SS, EJ46540108 SS, EJ46171008 SS, EJ46510208 SS, EJ46311008 SS | 100% |  | HEJ12 | HEJ12 | 86A |  | 0D | 999 |  | 200 | 200 | 070 | AD |  | LND | L2 | E | J | EJ00 | LUZ2 | OTH | LND | 3A |  |
| E3J04E15 |  | J04E Var.Area Flow. - Prel.Bid for PMT review | milestone | 0d | 2009-01-13 A | 2009-01-13 A | E3J04E20 SS-12d | 100% |  | E3J04E15 | E3J04E15 | 86B | J04E | 0D | 999 | 2JD7330 | 200 | 200 | 055 | E |  | LND | 0 | E | J | EJ34 | LUZ2 | I | LND |  |  |
| E3J12A15 |  | J12A Radar Level M.- Prel.Bid for PMT review | milestone | 0d | 2009-01-13 A | 2009-01-13 A | E3J12A20 SS-22d | 100% |  | E3J12A15 | E3J12A15 | 86B | J12A | 0D | 999 | 2JD8440 | 200 | 200 | 055 | E |  | LND | 0 | E | J | EJ34 | LUZ2 | I | LND |  |  |
| E3J04C20 |  | J04C Orifice/Venturi T. - Techn. Eval./PO Spec |  | 285d | 2009-01-22 A | 2010-03-10 A | P3J04CB FS+187d | 100% | TAP [2080 h] | E3J04C20 | E3J04C20 | 86B | J04C | 0D | 999 | 2JD7320 | 200 | 200 | 055 | E |  | LND | 0 | E | J | EJ34 | LUZ2 | PI | LND |  | 2080,00 |
| A1EJ0925 |  | I/O Quantity issued | milestone | 0d | 2009-01-30 A | 2009-01-30 A | A1EJ0915 SF+20d | 100% |  | A1EJ0925 | A1EJ0925 | 86A |  | 0D | 999 |  | 200 |  |  | E |  | LND |  | E | J | EJ00 | LUZ2 | I | LND |  |  |
| E3J1820 |  | J18 Weighing for Vessels - Techn. Eval./PO Spec |  | 299d | 2009-02-18 A | 2010-04-28 A | E3A1320 FF, P3J18B FS+15d | 100% | TAP [2080 h] | E3J1820 | E3J1820 | 86B | J18 | 0D | 999 | J18 | 200 | 200 | 055 | E |  | LND | 0 | E | J | EJ34 | LUZ2 | I | LND |  | 2080,00 |
| E3J12A20 |  | J12A Radar Level M. - Techn. Eval./PO Spec |  | 82d | 2009-02-19 A | 2009-06-19 A | P3J12AB FS+35d, HEJ20LE FF | 100% |  | E3J12A20 | E3J12A20 | 86B | J12A | 0D | 999 | 2JD8440 | 200 | 200 | 055 | E |  | LND | 0 | E | J | EJ34 | LUZ2 | I | LND |  |  |
| E3J12B10 |  | J12B Magn.Lev.Gauges - Inquiry Spec. |  | 15d | 2009-02-23 A | 2009-03-13 A | F2570 SS+120d | 100% |  | E3J12B10 | E3J12B10 | 86B | J12B | 0D | 999 | 2JD8470 | 200 | 200 | 055 | E | DEV | LND | 0 | E | J | EJ33 | LUZ2 | I | LND |  |  |
| E3J04E20 |  | J04E Var.Area Flow.(Rota) - Techn. Eval./PO Spec |  | 313d | 2009-02-24 A | 2010-05-26 A | HEJ20LE FF, P3J04EB FS+210d | 100% | TAP [2080 h] | E3J04E20 | E3J04E20 | 86B | J04E | 0D | 999 | 2JD7330 | 200 | 200 | 055 | E |  | LND | 0 | E | J | EJ34 | LUZ2 | I | LND |  | 2080,00 |
| E3J04C30 |  | J04C Orifice/Venturi T. - Techn.Eval./Bid Tab | milestone | 0d | 2009-02-25 A | 2009-02-25 A | E3J04C20 FF-28d, E3J04C15 SF | 100% |  | E3J04C30 | E3J04C30 | 86B | J04C | 0D | 999 | 2JD7320 | 200 | 200 | 055 | E |  | LND | 0 | E | J | EJ34 | LUZ2 | PI | LND |  |  |
| E3J13A10 |  | J13A Pressure Gauges - Inquiry Spec. |  | 13d | 2009-03-09 A | 2009-03-25 A | F2570 FS+130d | 100% |  | E3J13A10 | E3J13A10 | 86B | J13A | 0D | 999 | 2JD8480 | 200 | 200 | 055 | E | DEV | LND | 0 | E | J | EJ33 | LUZ2 | I | LND |  |  |
| E3J04A30 |  | J04A Coriolis Mass Flowm. -Techn.Eval./Bid Tab | milestone | 0d | 2009-03-12 A | 2009-03-12 A | E3J04A15 SF, E3J04A20 FF-21d | 100% |  | E3J04A30 | E3J04A30 | 86B | J04A | 0D | 999 | 2JD7280 | 200 | 200 | 055 | E |  | LND | 0 | E | J | EJ34 | LUZ2 | PI | LND |  |  |
| E3J04B30 |  | J04B Vortex Flowmeter -Techn.Eval./Bid Tab | milestone | 0d | 2009-03-12 A | 2009-03-12 A | E3J04B20 FF-15d, E3J04B15 SF | 100% |  | E3J04B30 | E3J04B30 | 86B | J04B | 0D | 999 | 2JD9260 | 200 | 200 | 055 | E |  | LND | 0 | E | J | EJ34 | LUZ2 | PI | LND |  |  |
| E3J12A30 |  | J12A Radar Level M. -Techn.Eval./Bid Tab | milestone | 0d | 2009-03-27 A | 2009-03-27 A | E3J12A15 SF, E3J12A20 FF-24d | 100% |  | E3J12A30 | E3J12A30 | 86B | J12A | 0D | 999 | 2JD8440 | 200 | 200 | 055 | E |  | LND | 0 | E | J | EJ34 | LUZ2 | I | LND |  |  |
| E3J13B10 |  | J13B Pressure Transm.- Inquiry Spec. |  | 15d | 2009-04-08 A | 2009-04-30 A | F2570 FS+130d | 100% |  | E3J13B10 | E3J13B10 | 86B | J13B | 0D | 999 | 2JD8690 | 200 | 200 | 055 | E | DEV | LND | 0 | E | J | EJ33 | LUZ2 | I | LND |  |  |
| E3J04E30 |  | J04E Var.Area Flow.(Rotam.) -Techn.Eval./Bid Tab | milestone | 0d | 2009-04-08 A | 2009-04-08 A | E3J04E20 FF-25d, E3J04E15 SF | 100% |  | E3J04E30 | E3J04E30 | 86B | J04E | 0D | 999 | 2JD7330 | 200 | 200 | 055 | E |  | LND | 0 | E | J | EJ34 | LUZ2 | I | LND |  |  |
| EJ000060 |  | Package Automation Contractor (PAC) selected PMT | milestone | 0d | 2009-04-09 A | 2009-04-09 A |  | 100% |  | EJ000060 | EJ000060 | 86A |  | 0D | 999 |  | 200 |  |  | E |  | PMT | L2 | E | J | EJ00 | LUZ2 | OTH | LND |  |  |
| EJ000080 |  | 3D Model Valves,JB's, Manifolds.. |  | 237d | 2009-04-14 A | 2010-03-22 A |  | 100% |  | EJ000080 | EJ000080 | 86A |  | 0D | 999 |  | 200 |  |  | E |  | LEI | L2 | E | J | EJ00 | LUZ2 | I | LND |  |  |
| EJ000090 |  | 3D Model Cable Tray's |  | 201d | 2009-04-14 A | 2010-01-29 A |  | 100% |  | EJ000090 | EJ000090 | 86A |  | 0D | 999 |  | 200 |  |  | E |  | LEI | L2 | E | J | EJ00 | LUZ2 | I | LND |  |  |
| EJ000100 |  | Air distributor connection list |  | 108d | 2009-05-04 A | 2009-10-02 A |  | 100% |  | EJ000100 | EJ000100 | 86A |  | 0D | 999 |  | 200 |  |  | E |  | LEI | L2 | E | J | EJ00 | LUZ2 | I | LND |  |  |
| EJ000184 |  | update Drwgs./Specs./Eng tools |  | 251d | 2009-05-04 A | 2010-04-30 A |  | 100% |  | EJ000184 | EJ000184 | 86A |  | 0D | 999 |  | 200 |  |  | E |  | LEI | L2 | E | J | EJ00 | LUZ2 | I | LND |  |  |
| EJ000110 |  | Auxillary Construction Drwgs./Install. supports |  | 108d | 2009-06-02 A | 2009-10-29 A |  | 100% |  | EJ000110 | EJ000110 | 86A |  | 0D | 999 |  | 200 |  |  | E |  | LEI | L2 | E | J | EJ00 | LUZ2 | I | LND |  |  |
| EJ000170 |  | Wiring Technical Rooms, Marshalling-Stand. |  | 149d | 2009-06-02 A | 2009-12-30 A |  | 100% |  | EJ000170 | EJ000170 | 86A |  | 0D | 999 |  | 200 |  |  | E |  | LEI | L2 | E | J | EJ00 | LUZ2 | I | LND |  |  |
| EJ000180 |  | JB's Field Multicore -Rev. assignment- |  | 149d | 2009-06-02 A | 2009-12-30 A |  | 100% |  | EJ000180 | EJ000180 | 86A |  | 0D | 999 |  | 200 |  |  | E |  | LEI | L2 | E | J | EJ00 | LUZ2 | I | LND |  |  |
| EJ000181 |  | Terminal Diagram |  | 149d | 2009-06-02 A | 2009-12-30 A |  | 100% |  | EJ000181 | EJ000181 | 86A |  | 0D | 999 |  | 200 |  |  | E |  | LEI | L2 | E | J | EJ00 | LUZ2 | I | LND |  |  |
| E3J1310 |  | J13 Diff.-/Press.Transm.(F/L) - Inquiry Spec. |  | 12d | 2009-06-25 A | 2009-07-10 A | F2570 FS+155d | 100% |  | E3J1310 | E3J1310 | 86B | J13 | 0D | 999 | 2JD8840 | 200 | 200 | 055 | E | DEV | LND | 0 | E | J | EJ33 | LUZ2 | I | LND |  |  |
| A1EJ0040 |  | Loop Diagramms development |  | 369d | 2009-06-29 A | 2010-12-09 A | A1EJ0020 FF+40d | 100% |  | A1EJ0040 | A1EJ0040 | 86A |  | 0D | 999 |  | 200 |  |  | E |  | LEI |  | E | J | EJ00 | LUZ2 | I | LND |  |  |
| E3J13A15 |  | J13A Pressure Gauges - Prel.Bid for PMT review | milestone | 0d | 2009-07-09 A | 2009-07-09 A | E3J13A20 SS-2d | 100% |  | E3J13A15 | E3J13A15 | 86B | J13A | 0D | 999 | 2JD8480 | 200 | 200 | 055 | E |  | LND | 0 | E | J | EJ34 | LUZ2 | I | LND |  |  |
| E3J04I15 |  | J04I Ultrasonic Flowm. - Prel.Bid for PMT review | milestone | 0d | 2009-07-15 A | 2009-07-15 A | E3J04I20 SS-3d | 100% |  | E3J04I15 | E3J04I15 | 86B | J04I | 0D | 999 | 2JD8500 | 200 | 200 | 055 | E |  | LND | 0 | E | J | EJ34 | LUZ2 | I | LND |  |  |
| E3J13B15 |  | J13B Pressure Transm. - Prel.Bid for PMT review | milestone | 0d | 2009-07-17 A | 2009-07-17 A | E3J13B20 SS-5d | 100% |  | E3J13B15 | E3J13B15 | 86B | J13B | 0D | 999 | 2JD8690 | 200 | 200 | 055 | E |  | LND | 0 | E | J | EJ34 | LUZ2 | I | LND |  |  |
| E3J0730 |  | J07 Analyser System -Techn.Eval./Bid Tab | milestone | 0d | 2009-07-17 A | 2009-07-17 A | E3J0715 SF, E3J0720 FF-13d | 100% |  | E3J0730 | E3J0730 | 86B | J07 | 0D | 999 | 2JD7560 | 200 | 200 | 055 | E |  | LND | 0 | E | J | EJ34 | LUZ2 | I | LND |  |  |
| E3J13C10 |  | J13C Pressure Switches - Inquiry Spec. |  | 15d | 2009-07-27 A | 2009-08-14 A | F2570 FS+130d | 100% |  | E3J13C10 | E3J13C10 | 86B | J13C | 0D | 999 | 2JD8960 | 200 | 200 | 055 | E | DEV | LND | 0 | E | J | EJ33 | LUZ2 | I | LND |  |  |
| E3J04B50 |  | J04B Vortex Flowmeter - Vendor dwgs approved | milestone | 0d | 2009-07-29 A | 2009-07-29 A | P3J04BD1 FF+35d | 100% |  | E3J04B50 | E3J04B50 | 86B | J04B | 0D | 999 | 2JD9260 | 200 | 200 |  | E |  | LND | 0 | E | J | EJ35 | LUZ2 | PI | LND |  |  |
| EJ000070 |  | Instrument installation index |  | 103d | 2009-08-05 A | 2009-12-30 A |  | 100% |  | EJ000070 | EJ000070 | 86A |  | 0D | 999 |  | 200 |  |  | E |  | LEI | L2 | E | J | EJ00 | LUZ2 | I | LND |  |  |
| E3J02A15 |  | J02A PCV Valves - Prel.Bid for PMT review | milestone | 0d | 2009-08-13 A | 2009-08-13 A | E3J02A20 SS-3d | 100% |  | E3J02A15 | E3J02A15 | 86B | J02A | 0D | 999 | 2AJ2660 | 200 | 200 | 055 | E |  | LND | 0 | E | J | EJ34 | LUZ2 | OTH | LND |  |  |
| E3J04A50 |  | J04A Coriolis Mass Flowmeter - Vendor dwgs appr. | milestone | 0d | 2009-08-14 A | 2009-08-14 A | P3J04AD1 FF+41d | 100% |  | E3J04A50 | E3J04A50 | 86B | J04A | 0D | 999 | 2JD7280 | 200 | 200 |  | E |  | LND | 0 | E | J | EJ35 | LUZ2 | PI | LND |  |  |
| E3J0515 |  | J05 MPS/CMS - Prel.Bid for PMT review | milestone | 0d | 2009-08-19 A | 2009-08-19 A | E3J0520 SS-15d | 100% |  | E3J0515 | E3J0515 | 86C | J05 | 0D | 999 | 2JD7520 | 200 | 200 | 055 | E |  | LND | 0 | E | J | EJ24 | LUZ2 | I | LND |  |  |
| E3J04I20 |  | J04I Ultrasonic Flowm. - Techn. Eval./PO Spec |  | 250d | 2009-09-03 A | 2010-08-31 A | P3J04IB FS+133d, HEJ20LE FF | 100% | TAP [2080 h] | E3J04I20 | E3J04I20 | 86B | J04I | 0D | 999 | 2JD8500 | 200 | 200 | 055 | E |  | LND | 0 | E | J | EJ34 | LUZ2 | I | LND |  | 2080,00 |
| E3J13B20 |  | J13B Pressure Transm. - Techn. Eval./PO Spec |  | 177d | 2009-09-08 A | 2010-05-25 A | P3J13BB FS+115d, HEJ20LE FF | 100% | TAP [2080 h] | E3J13B20 | E3J13B20 | 86B | J13B | 0D | 999 | 2JD8690 | 200 | 200 | 055 | E |  | LND | 0 | E | J | EJ34 | LUZ2 | I | LND |  | 2080,00 |
| E3J02B50 |  | J02B Knife Valves - Vendor dwgs approved | milestone | 0d | 2009-09-11 A | 2009-09-11 A | P3J02BD1 FF+75d | 100% |  | E3J02B50 | E3J02B50 | 86B | J02B | 0D | 999 | 2AJ3000 | 200 | 200 |  | E |  | LND | 0 | E | J | EJ35 | LUZ2 | PI | LND |  |  |

Notes:
- HEJ20LE: UDF_Actictity Name (Russia): Технический анализ/спецификации заказов на поставку, оборудование (LINDE)
- HEJ12: UDF_Actictity Name (Russia): Окончательные нагрузки по общестроительной части/металлоконструкциям
- EJ000060: UDF_Actictity Name (Russia): Выбор PMT подрядчика по автоматике проекта (PAC)
- EJ000080: UDF_Actictity Name (Russia): 3D-модель, запорная арматура, распределительные коробки, распределеители...
- EJ000090: UDF_Actictity Name (Russia): 3D-модель, кабельные лотки
- EJ000100: UDF_Actictity Name (Russia): Перечень соединений распределения воздуха
- EJ000184: UDF_Actictity Name (Russia): Обновление чертежей/спецификаций/инженерного инструментария
- EJ000110: UDF_Actictity Name (Russia): Чертежи вспомогательных конструкций/монтажных опор
- EJ000170: UDF_Actictity Name (Russia): Проводка в технические помещения, стандартная маршрутизация
- EJ000180: UDF_Actictity Name (Russia): Многожильные кабели полевых распределительных коробок, обзор распределения
- EJ000181: UDF_Actictity Name (Russia): Схема клеммных соединений
- E3J04B50: Expenses: 900A 0
- EJ000070: UDF_Actictity Name (Russia): Индексация установки оборудования
- E3J04A50: Expenses: 900A 0
- E3J02B50: Expenses: 900A 0

| ID | Activity | Type | Duration | Start | Finish | Predecessors | Complete | Resources | UDF_SAVE ACTID | UDF_SAVE ACT ID | Department | Type of Work | Constr. Area | Pro Unit/DocCode | Inquiry/Order No | PMT-Area | PMT-Schedule Org | PMT-Phase | PMT-Respons. | Zeigen/n. Zeigen | WBS Phase | WBS Discipline | WBS Type of Work | WBS Objects | IMS | UPT | TB26 Ressource Budget | PMT-Discipline | PMT-Doc. Type | PMT-Stage |
| --- | --- | --- | --- | --- | --- | --- | --- | --- | --- | --- | --- | --- | --- | --- | --- | --- | --- | --- | --- | --- | --- | --- | --- | --- | --- | --- | --- | --- | --- | --- |
| E3J02D50 | J02D ON/OFF Plug Valves - Vendor dwgs approved | milestone | 0d | 2009-09-11 A | 2009-09-11 A | P3J02DD1 FF+55d | 100% |  | E3J02D50 | E3J02D50 | 86B | J02D | 0D | 999 | 2AJ3020 | 200 | 200 | E | LND | 0 | E | J | EJ35 | LUZ2 | PI | LND |  |  |  |  |
| E3J14A10 | J14A Thermowell+Elements - Inquiry Spec. |  | 19d | 2009-09-14 A | 2009-10-08 A | F2570 SS+120d, E3J12B10 FS+135d | 100% | TAP [1280 h] | E3J14A10 | E3J14A10 | 86B | J14A | 0D | 999 | 2JD8720 | 200 | 200 | E | LND | 0 | E | J | EJ33 | LUZ2 | I | LND | 1280,00 | 055 | DEV |  |
| E3J02C50 | J02C Butterfly Valves on/off - Vendor dwgs appr. | milestone | 0d | 2009-09-14 A | 2009-09-14 A | P3J02CD1 FF+75d | 100% |  | E3J02C50 | E3J02C50 | 86B | J02C | 0D | 999 | 2AJ3090 | 200 | 200 | E | LND | 0 | E | J | EJ35 | LUZ2 | PI | LND |  |  |  |  |
| E3J12B15 | J12B Magn.Lev.Gauges- Prel.Bid for PMT review | milestone | 0d | 2009-09-15 A | 2009-09-15 A | E3J12B20 SS-3d | 100% |  | E3J12B15 | E3J12B15 | 86B | J12B | 0D | 999 | 2JD8470 | 200 | 200 | E | LND | 0 | E | J | EJ34 | LUZ2 | I | LND |  | 055 |  |  |
| E3J0250 | J02 Control Valves - Vendor dwgs approved (TKK reviewed) | milestone | 0d | 2009-09-18 A | 2009-09-18 A | P3J02D1 FF+49d | 100% |  | E3J0250 | E3J0250 | 86B | J02 | 0D | 999 | 2AJ3030 | 200 | 200 | E | LND | 0 | E | J | EJ35 | LUZ2 | OTH | LND |  |  |  |  |
| E3J1410 | J14 Temp.Transm./Thermocouple - Inquiry Spec. |  | 14d | 2009-09-21 A | 2009-10-08 A | F2570 SS+145d, E3J14A10 SS+5d | 100% | TAP [1280 h] | E3J1410 | E3J1410 | 86B | J14 | 0D | 999 | 2JD8710 | 200 | 200 | E | LND | 0 | E | J | EJ33 | LUZ2 | I | LND | 1280,00 | 055 | DEV |  |
| E3J14B10 | J14B Temp. Gauges - Inquiry Spec. |  | 14d | 2009-09-21 A | 2009-10-08 A | F2570 FS+140d, E3J14A10 SS+10d | 100% | TAP [1280 h] | E3J14B10 | E3J14B10 | 86B | J14B | 0D | 999 | 2JD8700 | 200 | 200 | E | LND | 0 | E | J | EJ33 | LUZ2 | I | LND | 1280,00 | 055 | DEV |  |
| E3J12D10 | J12D Vibration Fork Level Switch - Inquiry Spec. |  | 15d | 2009-10-05 A | 2009-10-23 A | E3J1310 SS+35d, F2570 SS+140d | 100% | TAP [1280 h] | E3J12D10 | E3J12D10 | 86B | J12D | 0D | 999 | 2JD9190 | 200 | 200 | E | LEI | 0 | E | J | EJ33 | LUZ2 | I | LND | 1280,00 | 055 | DEV |  |
| EJ000120 | MTO f. Cable, Cable tray, Mechan. & Construction |  | 39d | 2009-10-05 A | 2009-11-27 A |  | 100% |  | EJ000120 | EJ000120 | 86A |  | 0D | 999 |  | 200 |  | E | LEI | L2 | E | J | EJ00 | LUZ2 | I | LND |  |  |  |  |
| E3J02A20 | J02A PCV Valves - Techn. Eval./PO Spec |  | 84d | 2009-10-08 A | 2010-02-09 A | P3J02AB FS+367d, HEJ20LE FF | 100% | TAP [2080 h] | E3J02A20 | E3J02A20 | 86B | J02A | 0D | 999 | 2AJ2660 | 200 | 200 | E | LND | 0 | E | J | EJ34 | LUZ2 | I | LND | 2080,00 | 055 |  |  |
| E3J01A50 | J01A Ball Valves - Vendor dwgs approved (TKK reviewed) | milestone | 0d | 2009-10-16 A | 2009-10-16 A | P3J01AD1 FS+45d | 100% |  | E3J01A50 | E3J01A50 | 86B | J01A | 0D | 999 | 2AJ2610 | 200 | 200 | E | LND | 0 | E | J | EJ35 | LUZ2 | PI | LND |  |  |  |  |
| EJ000165 | Participation 60% DSRV -downstream- | level of effort | 7d | 2009-10-19 A | 2009-10-27 A | F4035 SS, F4035 FF | 100% |  | EJ000165 | EJ000165 | 86A |  | 0D | 999 |  | 200 | 200 | AD | LND | 1 | E | J | EJ00 | LUZ2 | I | LND |  | 070 |  | 3A |
| E3J13A20 | J13A Pressure Gauges - Techn. Eval./PO Spec |  | 165d | 2009-10-20 A | 2010-06-18 A | P3J13AB FS+140d, HEJ20LE FF | 100% | TAP [2080 h] | E3J13A20 | E3J13A20 | 86B | J13A | 0D | 999 | 2JD8480 | 200 | 200 | E | LND | 0 | E | J | EJ34 | LUZ2 | I | LND | 2080,00 | 055 |  |  |
| E3J12B20 | J12B Magn.Lev.Gauges - Techn. Eval./PO Spec |  | 74d | 2009-10-23 A | 2010-02-10 A | P3J12BB FS+150d, HEJ20LE FF | 100% | TAP [2080 h] | E3J12B20 | E3J12B20 | 86B | J12B | 0D | 999 | 2JD8470 | 200 | 200 | E | LND | 0 | E | J | EJ34 | LUZ2 | I | LND | 2080,00 | 055 |  |  |
| E3J0150 | J01 Ball Valves PDS - Vendor dwgs approved (TKK reviewed) | milestone | 0d | 2009-10-23 A | 2009-10-23 A | P3J01D1 FF+95d | 100% |  | E3J0150 | E3J0150 | 86B | J01 | 0D | 999 | 2AJ2620 | 200 | 200 | E | LND | 0 | E | J | EJ35 | LUZ2 | OTH | LND |  |  |  |  |
| E3J13C15 | J13C Pressure Switches - Prel.Bid for PMT review | milestone | 0d | 2009-10-27 A | 2009-10-27 A | E3J13C20 SS-3d | 100% |  | E3J13C15 | E3J13C15 | 86B | J13C | 0D | 999 | 2JD8960 | 200 | 200 | E | LND | 0 | E | J | EJ34 | LUZ2 | I | LND |  | 055 |  |  |
| HEJ20LB | Techn. Eval./PO Spec's Bulk (LINDE) | level of effort | 234d | 2009-10-27 A | 2010-09-30 A | E3J06B20 FF, E3J06F20 SS, E3J0520 SS, E3J06A20 SS | 100% |  | HEJ20LB | HEJ20LB | 86A |  | 0D | 999 |  | 200 | 200 | AD | LND | L2 | E | J | EJ00 | LUZ2 | I | LND |  | 070 |  | 3A |
| EJ000160 | Participation 60% DSRV -upstream- 11/12/13/51/55-56 | level of effort | 12d | 2009-11-02 A | 2009-11-17 A | F4030 SS, F4030 FF, EJ000165 | 100% |  | EJ000160 | EJ000160 | 86A |  | 0D | 999 |  | 200 | 200 | AD | LND | 1 | E | J | EJ00 | LUZ2 | I | LND |  | 070 |  | 3A |
| EJ000182 | Cable Lists |  | 40d | 2009-11-02 A | 2009-12-30 A |  | 100% |  | EJ000182 | EJ000182 | 86A |  | 0D | 999 |  | 200 |  | E | LEI | L2 | E | J | EJ00 | LUZ2 | I | LND |  |  |  |  |
| EJ000183 | Cable Routing |  | 40d | 2009-11-02 A | 2009-12-30 A |  | 100% |  | EJ000183 | EJ000183 | 86A |  | 0D | 999 |  | 200 |  | E | LEI | L2 | E | J | EJ00 | LUZ2 | I | LND |  |  |  |  |
| HEJ20G | Techn. Eval./PO Spec's (GC) | level of effort | 260d | 2009-11-02 A | 2010-11-11 A | E3J1735 FF | 100% |  | HEJ20G | HEJ20G | 86A |  | 0D | 999 |  | 200 | 200 | AD | CC | L2 | E | J | EJ00 | LUZ2 | I | LND |  | 070 |  | 3A |
| EJ000185 | Insul.& Heat tracing (install. material) |  | 32d | 2009-11-09 A | 2009-12-23 A |  | 100% |  | EJ000185 | EJ000185 | 86A |  | 0D | 999 |  | 200 |  | E | LEI | L2 | E | J | EJ00 | LUZ2 | I | LND |  |  |  |  |
| E3J13C20 | J13C Pressure Switches - Techn. Eval./PO Spec |  | 134d | 2009-11-25 A | 2010-06-10 A | P3J13CB FS+110d, HEJ20LE FF | 100% | TAP [2080 h] | E3J13C20 | E3J13C20 | 86B | J13C | 0D | 999 | 2JD8960 | 200 | 200 | E | LND | 0 | E | J | EJ34 | LUZ2 | I | LND | 2080,00 | 055 |  |  |
| EJ000130 | BOQ & scope of work Construction |  | 41d | 2009-11-30 A | 2010-01-29 A | EJ000120 | 100% |  | EJ000130 | EJ000130 | 86A |  | 0D | 999 |  | 200 |  | E | LEI | L2 | E | J | EJ00 | LUZ2 | I | LND |  |  |  |  |
| EJ000140 | Spec. f. testing process contr. /instr. equipm. |  | 41d | 2009-11-30 A | 2010-01-29 A | EJ000130 SS | 100% |  | EJ000140 | EJ000140 | 86A |  | 0D | 999 |  | 200 |  | E | LEI | L2 | E | J | EJ00 | LUZ2 | I | LND |  |  |  |  |
| EJ000150 | Name plate list |  | 21d | 2009-11-30 A | 2009-12-30 A | EJ000130 SS | 100% |  | EJ000150 | EJ000150 | 86A |  | 0D | 999 |  | 200 |  | E | LEI | L2 | E | J | EJ00 | LUZ2 | I | LND |  |  |  |  |
| EJ000065 | Basic Spec's (FEED) Automation System Yokogawa (PAC) |  | 80d | 2009-12-01 A | 2010-03-26 A | P3J06B, P3J06B1 FF | 100% |  | EJ000065 | EJ000065 | 86A |  | 0D | 999 |  | 200 |  | E | YGW |  | E | J | EJ00 | LUZ2 | I | LND |  |  |  |  |
| EJ000225 | List of Instrumentation Documentation |  | 290d | 2009-12-01 A | 2011-01-25 A | IMS-E-000210 FF, EJ1000 FF+20d | 100% | TAP [2560 h] | EJ000225 | EJ000225 | 86A |  | 0D | 999 |  | 200 |  | E | LND |  | E | J | EJ00 | LUZ2 | I | LND | 2560,00 |  |  |  |
| EJ000230 | Calcualtion/Verif. of Intrinsic- / Safety Integrety Level |  | 329d | 2009-12-01 A | 2011-03-21 A | IMS-E-000210 FF, DE1000 | 100% | TAP [5760 h] | EJ000230 | EJ000230 | 86A |  | 0D | 999 |  | 200 |  | E | LEI |  | E | J | EJ00 | LUZ2 | I | LND | 5760,00 |  |  |  |
| EJ000255 | 3D Modelling |  | 208d | 2009-12-01 A | 2010-09-28 A | DE1000 | 100% | TAP [20000 h] | EJ000255 | EJ000255 | 86A |  | 0D | 999 |  | 200 |  | E | LND |  | E | J | EJ00 | LUZ2 | I | LND | 20000,00 |  |  |  |
| EJ1000 | General Tasks & Coordinations DE Phase (Instrum.) |  | 304d | 2009-12-01 A | 2011-02-14 A | DE1000 | 100% | TAP [15360 h] | EJ1000 | EJ1000 | 86A |  | 0D | 999 |  | 200 |  | E | LND |  | E | J | EJ00 | LUZ2 | I | LND | 15360,00 |  |  |  |
| EJ143130 | Layout Control Room - Service Area |  | 218d | 2009-12-01 A | 2010-10-12 A | EC45313005 FF | 100% | TAP [640 h] | EJ143130 | EJ143130 | 86A |  | 0D | 999 |  | 200 |  | E | LND |  | E | J | EJ14 | LUZ2 | I | LND | 640,00 |  |  |  |
| E3J1320 | J13 Diff.-/Press.Transm.(F/L) - Techn. Eval./PO Spec |  | 117d | 2009-12-02 A | 2010-05-25 A | P3J13B FS+120d, HEJ20LE FF | 100% | TAP [4160 h] | E3J1320 | E3J1320 | 86B | J13 | 0D | 999 | 2JD8840 | 200 | 200 | E | LND | 0 | E | J | EJ34 | LUZ2 | I | LND | 4160,00 | 055 |  |  |
| E3J14B20 | J14B Temp. Gauges - Techn. Eval./PO Spec |  | 107d | 2009-12-02 A | 2010-05-07 A | P3J14BB FS+70d, HEJ20LE FF | 100% | TAP [2080 h] | E3J14B20 | E3J14B20 | 86B | J14B | 0D | 999 | 2JD8700 | 200 | 200 | E | LND | 0 | E | J | EJ34 | LUZ2 | I | LND | 2080,00 | 055 |  |  |
| E3J0560 | J05 MPS/CMS - techn. clarification/assistance |  | 99d | 2009-12-07 A | 2010-04-30 A | E3J0520 FF+70d | 100% | TAP [3200 h] | E3J0560 | E3J0560 | 86B | J05 | 0D | 999 | 2JD7520 | 200 | 200 | E | LND | 0 | E | J | EJ35 | LUZ2 | PI | LND | 3200,00 |  |  |  |
| E3J0760 | J07 Analyser System - techn. clarification/assistance |  | 140d | 2009-12-07 A | 2010-06-30 A | E3J0720 FF+100d | 100% | TAP [7200 h] | E3J0760 | E3J0760 | 86B | J07 | 0D | 999 | 2JD7560 | 200 | 200 | E | LND | 0 | E | J | EJ35 | LUZ2 | PI | LND | 7200,00 |  |  |  |
| E3J1735 | J17 Instrument Cable - Preparation Final BOQ / PO Spec |  | 315d | 2009-12-07 A | 2011-03-07 A | F4460 FF+10d | 100% | TAP [8320 h] | E3J1735 | E3J1735 | 86E | J17 | 0D | 999 | 2JD9530 | 200 | 200 | E | LND | 0 | E | J | EJ54 | LUZ2 | I | LND | 8320,00 | 055 |  |  |
| EJ000200 | Detailed Connection list for instr. air tubing / manifold |  | 224d | 2009-12-07 A | 2010-10-26 A | P3R09BB FF+50d, DE1000 | 100% | TAP [2560 h] | EJ000200 | EJ000200 | 86A |  | 0D | 999 |  | 200 |  | E | LEI |  | E | J | EJ00 | LUZ2 | I | LND | 2560,00 |  |  |  |
| E3J1420 | J14 Temp.Tr./Thermocouple - Techn. Eval./PO Spec |  | 110d | 2009-12-09 A | 2010-05-20 A | P3J14B FS+60d, HEJ20LE FF | 100% | TAP [2080 h] | E3J1420 | E3J1420 | 86B | J14 | 0D | 999 | 2JD8710 | 200 | 200 | E | LND | 0 | E | J | EJ34 | LUZ2 | I | LND | 2080,00 | 055 |  |  |
| E3J14A20 | J14A Thermowell+Elements - Techn. Eval./PO Spec |  | 166d | 2009-12-09 A | 2010-08-09 A | P3J14AB FS+60d, HEJ20LE FF | 100% | TAP [2080 h] | E3J14A20 | E3J14A20 | 86B | J14A | 0D | 999 | 2JD8720 | 200 | 200 | E | LND | 0 | E | J | EJ34 | LUZ2 | I | LND | 2080,00 | 055 |  |  |
| E3J06F20 | J06F PLC Network - Techn. Eval./PO Spec |  | 202d | 2009-12-11 A | 2010-09-30 A | P3J06FB FS+220d | 100% | TAP [1280 h] | E3J06F20 | E3J06F20 | 86C | J06F | 0D | 999 | 2JD8450 | 200 | 200 | E | LND | 0 | E | J | EJ24 | LUZ2 | I | LND | 1280,00 | 055 |  |  |
| E3J12D20 | J12D Vibration Fork Level Switch - Techn. Eval./PO Spec |  | 237d | 2009-12-14 A | 2010-11-22 A | P3J12DB FS+60d | 100% | TAP [2080 h] | E3J12D20 | E3J12D20 | 86B | J12D | 0D | 999 | 2JD9190 | 200 | 200 | E | LEI | 0 | E | J | EJ34 | LUZ2 | I | LND | 2080,00 | 055 |  |  |
| EJ000205 | Instrument Equipment Installation Typicals |  | 148d | 2009-12-14 A | 2010-07-19 A | DE1000 FS+10d | 100% | TAP [1280 h] | EJ000205 | EJ000205 | 86A |  | 0D | 999 |  | 200 |  | E | LND |  | E | J | EJ00 | LUZ2 | I | LND | 1280,00 |  |  |  |
| EJ000215 | Instrument Design Index |  | 221d | 2009-12-14 A | 2010-10-28 A | DE1000 FS+10d | 100% | TAP [3200 h] | EJ000215 | EJ000215 | 86A |  | 0D | 999 |  | 200 |  | E | LND |  | E | J | EJ00 | LUZ2 | I | LND | 3200,00 |  |  |  |
| EJ000220 | Instrument Engineering Index |  | 264d | 2009-12-14 A | 2010-12-30 A | EJ000215 SS | 100% | TAP [3200 h] | EJ000220 | EJ000220 | 86A |  | 0D | 999 |  | 200 |  | E | LND |  | E | J | EJ00 | LUZ2 | I | LND | 3200,00 |  |  |  |
| EJ000235 | Instrument Electrical Supply and Grounding |  | 220d | 2009-12-15 A | 2010-10-28 A | EE900010 SS | 100% | TAP [1280 h] | EJ000235 | EJ000235 | 86A |  | 0D | 999 |  | 200 |  | E | LND |  | E | J | EJ00 | LUZ2 | I | LND | 1280,00 |  |  |  |
| EJ000250 | Fibre Optic Network Diagram |  | 141d | 2010-01-04 A | 2010-07-23 A | EJ000245 FF-10d | 100% |  | EJ000250 | EJ000250 | 86A |  | 0D | 999 |  | 200 |  | E | LND |  | E | J | EJ00 | LUZ2 | I | LND |  |  |  |  |
| E3J12B30 | J12B Magn.Lev.Gauges -Techn.Eval./Bid Tab | milestone | 0d | 2010-01-05 A | 2010-01-05 A | E3J12B15 SF, E3J12B20 FF-8d | 100% |  | E3J12B30 | E3J12B30 | 86B | J12B | 0D | 999 | 2JD8470 | 200 | 200 | E | LND | 0 | E | J | EJ34 | LUZ2 | I | LND |  | 055 |  |  |
| EJ000245 | Network Cable |  | 279d | 2010-01-11 A | 2011-02-14 A | E3J06F20 FF | 100% | TAP [5120 h] | EJ000245 | EJ000245 | 86A |  | 0D | 999 |  | 200 |  | E | LND |  | E | J | EJ00 | LUZ2 | I | LND | 5120,00 |  |  |  |
| E3J1830 | J18 Weighing for Vessels -Techn.Eval./Bid Tab | milestone | 0d | 2010-01-18 A | 2010-01-18 A | E3J1815 SF, E3J1820 FF-15d | 100% |  | E3J1830 | E3J1830 | 86B | J18 | 0D | 999 | J18 | 200 | 200 | E | LND | 0 | E | J | EJ34 | LUZ2 | I | LND |  | 055 |  |  |
| HEJ36 | Hook up Dwgs | level of effort | 102d | 2010-01-18 A | 2010-06-14 A | EJ363110 SS, EJ361201 SS, EJ363140 SS, EJ361710 SS, EJ363120 SS | 100% |  | HEJ36 | HEJ36 | 86A |  | 0D | 999 |  | 200 | 200 | AD | LEI | L2 | E | J | EJ00 | LUZ2 | I | LND |  | 070 |  | 3A |
| E3J02A30 | J02A PCV Valves -Techn. Eval./Bid Tab | milestone | 0d | 2010-01-27 A | 2010-01-27 A | E3J02A15 SF, E3J02A20 FF-10d | 100% |  | E3J02A30 | E3J02A30 | 86B | J02A | 0D | 999 | 2AJ2660 | 200 | 200 | E | LND | 0 | E | J | EJ34 | LUZ2 | I | LND |  | 055 |  |  |
| EJ000210 | List of Installation Mounting Material |  | 265d | 2010-01-29 A | 2011-02-14 A | EJ000205 SS+30d | 100% | TAP [2560 h] | EJ000210 | EJ000210 | 86A |  | 0D | 999 |  | 200 |  | E | LND |  | E | J | EJ00 | LUZ2 | I | LND | 2560,00 |  |  |  |
| E3J0940 | J09 Instr.Cable Trays+Bulk - Preparation Final BOQ / PO Spec |  | 71d | 2010-02-15 A | 2010-05-28 A | F4030 FF+10d, F4035 FF+10d, F4040 FF+10d, P3E16D FF-40d | 100% | TAP [640 h] | E3J0940 | E3J0940 | 86E | J09 | 0D | 999 | J09 | 200 | 200 | E | LND | 0 | E | J | EJ43 | LUZ2 | I | LND | 640,00 | 055 | DEV |  |
| E3J1510 | J15 Winterization Enclosures - Inquiry Spec. |  | 13d | 2010-02-22 A | 2010-03-10 A | E3J1410 | 100% |  | E3J1510 | E3J1510 | 86B | J15 | 0D | 999 | 2JD9450 | 200 | 200 | E | LEI | 0 | E | J | EJ33 | LUZ2 | I | LND |  | 055 | DEV |  |
| EJ000175 | Participation 60% DSRV -upstream- 15/16/17/52,54 | level of effort | 15d | 2010-03-01 A | 2010-03-19 A | F4040 SS, EJ000160, F4040 FF | 100% |  | EJ000175 | EJ000175 | 86A |  | 0D | 999 |  | 200 | 200 | AD | LND | 1 | E | J | EJ00 | LUZ2 | I | LND |  | 070 |  | 3A |
| HEJ46 | Cable Tray Layout Plans | level of effort | 228d | 2010-03-01 A | 2011-01-21 A | EJ46312010 SS, EJ46510210 SS, EJ46171010 SS, EJ46311010 SS, EJ46314010 SS, EJ461610 SS, EJ46540110 SS | 100% |  | HEJ46 | HEJ46 | 86A |  | 0D | 999 |  | 200 | 200 | AD | LND | L2 | E | J | EJ00 | LUZ2 | I | LND |  | 070 |  | 3A |
| E3J02A50 | J02A PCV Valves - Vendor dwgs approved | milestone | 0d | 2010-03-05 A | 2010-03-05 A | IMS-E-000220 FF, P3J02AL SF+45d | 100% |  | E3J02A50 | E3J02A50 | 86B | J02A | 0D | 999 | 2AJ2660 | 200 | 200 | E | LND | 0 | E | J | EJ35 | LUZ2 | PI | LND |  |  |  |  |
| EJ141610 | Layout RIE Room - Substation |  | 145d | 2010-03-15 A | 2010-10-07 A | EC45161005 FF+30d | 100% | TAP [1280 h] | EJ141610 | EJ141610 | 86A |  | 0D | 999 |  | 200 |  | E | LND |  | E | J | EJ14 | LUZ2 | I | LND | 1280,00 |  |  |  |
| E3J07A10 | J07A Sample Boards - Inquiry Spec. |  | 10d | 2010-03-22 A | 2010-04-06 A | F2570 SS, E3J06A10 SS | 100% | TAP [1280 h] | E3J07A10 | E3J07A10 | 86B | J07A | 0D | 999 | 2JD9480 | 200 | 200 | E | LND | 0 | E | J | EJ33 | LUZ2 | I | LND | 1280,00 | 055 | DEV |  |
| EJ141710 | Layout Sound Enclosure Room - Extrusion Bldg |  | 138d | 2010-03-22 A | 2010-10-05 A | EC45170005 SS+60d | 100% | TAP [640 h] | EJ141710 | EJ141710 | 86A |  | 0D | 999 |  | 200 |  | E | LND |  | E | J | EJ14 | LUZ2 | I | LND | 640,00 |  |  |  |
| E3J0750 | J07 Analyser System - Vendor dwgs approved | milestone | 0d | 2010-03-22 A | 2010-03-22 A | P3J07D FF+54d | 100% |  | E3J0750 | E3J0750 | 86B | J07 | 0D | 999 | 2JD7560 | 200 | 200 | E | LND | 0 | E | J | EJ35 | LUZ2 | PI | LND |  |  |  |  |
| E3J12B50 | J12B Magn.Lev.Gauges - Vendor dwgs appr. | milestone | 0d | 2010-03-24 A | 2010-03-24 A | P3J12BL SF+30d | 100% |  | E3J12B50 | E3J12B50 | 86B | J12B | 0D | 999 | 2JD8470 | 200 | 200 | E | LND | 0 | E | J | EJ35 | LUZ2 | I | LND |  |  |  |  |
| E3J13B30 | J13B Pressure Transm. -Techn.Eval./Bid Tab | milestone | 0d | 2010-03-25 A | 2010-03-25 A | E3J13B20 FF-10d, E3J13B15 SF | 100% |  | E3J13B30 | E3J13B30 | 86B | J13B | 0D | 999 | 2JD8690 | 200 | 200 | E | LND | 0 | E | J | EJ34 | LUZ2 | I | LND |  | 055 |  |  |
| E3J14B30 | J14B Temp. Gauges -Techn.Eval./Bid Tab | milestone | 0d | 2010-03-29 A | 2010-03-29 A | E3J14B20 FF-13d | 100% |  | E3J14B30 | E3J14B30 | 86B | J14B | 0D | 999 | 2JD8700 | 200 | 200 | E | LND | 0 | E | J | EJ34 | LUZ2 | I | LND |  | 055 |  |  |
| E3J1520 | J15 Winterization Enclosures - Techn. Eval./PO Spec |  | 112d | 2010-03-31 A | 2010-09-08 A | P3J15B FS+60d | 100% |  | E3J1520 | E3J1520 | 86B | J15 | 0D | 999 | 2JD9450 | 200 | 200 | E | LEI | 0 | E | J | EJ34 | LUZ2 | I | LND |  | 055 |  |  |
| E3J06E10 | J06E Junction Boxes - Inquiry Spec. |  | 20d | 2010-04-12 A | 2010-05-07 A | F2600 FS+85d | 100% | TAP [1280 h] | E3J06E10 | E3J06E10 | 86C | J06E | 0D | 999 | 2JD9620 | 200 | 200 | E | LND | 0 | E | J | EJ23 | LUZ2 | I | LND | 1280,00 | 055 | DEV |  |
| E3J1330 | J13 Diff.-/Press.Transm.(F/L) -Techn.Eval./Bid Tab | milestone | 0d | 2010-04-12 A | 2010-04-12 A | E3J1320 FF-10d | 100% |  | E3J1330 | E3J1330 | 86B | J13 | 0D | 999 | 2JD8840 | 200 | 200 | E | LND | 0 | E | J | EJ34 | LUZ2 | I | LND |  | 055 |  |  |
| E3J04C50 | J04C Orifice/Venturi T. - Vendor dwgs approved | milestone | 0d | 2010-04-14 A | 2010-04-14 A | P3J04CL SF+35d | 100% |  | E3J04C50 | E3J04C50 | 86B | J04C | 0D | 999 | 2JD7320 | 200 | 200 | E | LND | 0 | E | J | EJ35 | LUZ2 | I | LND |  |  |  |  |
| E3J0665 | J06 DCS / SIS - administration, techn. support |  | 236d | 2010-04-19 A | 2011-03-21 A | P3J06L FF-25d | 100% | TAP [27008 h] | E3J0665 | E3J0665 | 86B | J06 | 0D | 999 | 2JD9220 | 200 | 200 | E | LND | 0 | E | J | EJ35 | LUZ2 | PI | LND | 27008,00 |  |  |  |

Notes:
- E3J02D50: Expenses: 900A 0
- E3J02C50: Expenses: 900A 0
- E3J0250: Expenses: 900A 0
- EJ000120: UDF_Actictity Name (Russia): MTO на кабели, кабельные лотки, механическую и строительную часть
- E3J01A50: Expenses: 900A 0
- E3J0150: Expenses: 900A 0
- HEJ20LB: UDF_Actictity Name (Russia): Технический анализ/спецификации заказов на поставку, насыпные материалы (LINDE)
- EJ000182: UDF_Actictity Name (Russia): Перечни кабелей
- EJ000183: UDF_Actictity Name (Russia): Прокладка кабелей
- HEJ20G: UDF_Actictity Name (Russia): Технический анализ/спецификации заказов на поставку (GC)
- EJ000185: UDF_Actictity Name (Russia): Изоляция и теплоспутники (с материалом для монтажа)
- EJ000130: UDF_Actictity Name (Russia): Спецификации объемов работ и объем работ, строительство
- EJ000140: UDF_Actictity Name (Russia): Спецификации процесса тестирования контрольно-измерительного оборудования
- EJ000150: UDF_Actictity Name (Russia): Перечень паспортных табличек
- HEJ36: UDF_Actictity Name (Russia): Принципиальные схемы
- HEJ46: UDF_Actictity Name (Russia): Схемы расположения кабельных лотков
- E3J02A50: Expenses: 900A 0
- E3J0750: Expenses: 900A 0
- E3J12B50: Expenses: 900A 0
- E3J04C50: Expenses: 900A 0

| ID | Activity | Type | Duration | Start | Finish | Predecessors | Complete | Remaining | Total float | Free float | Resources | UDF_SAVE ACTID | UDF_SAVE ACT ID | Department | Type of Work | Constr. Area | Pro Unit/DocCode | Inquiry/Order No | PMT-Area | PMT-Schedule Org | PMT-Discipline | PMT-Phase | PMT-Doc. Type | PMT-Respons. | Zeigen/n. Zeigen | WBS Phase | WBS Discipline | WBS Type of Work | WBS Objects | IMS | UPT | TB26 Ressource Budget | PMT-Stage | UDF_Actictity Name (Russia) |
| --- | --- | --- | --- | --- | --- | --- | --- | --- | --- | --- | --- | --- | --- | --- | --- | --- | --- | --- | --- | --- | --- | --- | --- | --- | --- | --- | --- | --- | --- | --- | --- | --- | --- | --- |
| E3J07C10 | J07C Local Indicat. Panels - Inquiry Spec. |  | 10d | 2010-04-23 A | 2010-05-06 A | F2570 | 100% |  |  |  |  | E3J07C10 | E3J07C10 | 86B | J07C | 0D | 999 | 2JD9500 | 200 | 200 | 055 | E | DEV | LEI | 0 | E | J | EJ33 | LUZ2 | I | LND |  |  |  |
| E3J06A10 | J06A Power Supply Cabinets - Inquiry Spec. |  | 24d | 2010-04-26 A | 2010-05-31 A | E3J0612 FS+90d, F2600 SS | 100% |  |  |  | TAP [640 h] | E3J06A10 | E3J06A10 | 86C | J06A | 0D | 999 | 2JD9640 | 200 | 200 | 055 | E | DEV | LND | 0 | E | J | EJ23 | LUZ2 | I | LND | 640,00 |  |  |
| E3J07A20 | J07A Sample Boards - Techn. Eval./PO Spec |  | 136d | 2010-04-26 A | 2010-11-03 A | P3J07AB FS+25d | 100% |  |  |  | TAP [2080 h] | E3J07A20 | E3J07A20 | 86B | J07A | 0D | 999 | 2JD9480 | 200 | 200 | 055 | E |  | LND | 0 | E | J | EJ34 | LUZ2 | I | LND | 2080,00 |  |  |
| EJ000190 | Participation 90% DSRV -downstream- | level of effort | 10d | 2010-04-26 A | 2010-05-07 A | F9250 SS, F9250 FF, EJ000175 | 100% |  |  |  |  | EJ000190 | EJ000190 | 86A |  | 0D | 999 |  | 200 | 200 | 070 | AD |  | LND | 1 | E | J | EJ00 | LUZ2 | I | LND |  | 3A |  |
| E3J1710 | J17 Instrument Cable - Inquiry Spec. |  | 20d | 2010-04-29 A | 2010-05-28 A | P3E00C1 SS+21d | 100% |  |  |  |  | E3J1710 | E3J1710 | 86B | J17 | 0D | 999 | 2JD9530 | 200 | 200 | 055 | E | DEV | LEI | 0 | E | J | EJ33 | LUZ2 | PI | LND |  |  |  |
| E3J06B10 | J06B Interface/Special Dev. Cabinets (E+I) - Inquiry Spec. |  | 19d | 2010-05-03 A | 2010-05-31 A | E3J06A10 FF, F2600 FS+85d | 100% |  |  |  | TAP [1280 h] | E3J06B10 | E3J06B10 | 86C | J06B | 0D | 999 | 2JD9640 | 200 | 200 | 055 | E | DEV | LND | 0 | E | J | EJ23 | LUZ2 | I | LND | 1280,00 |  |  |
| E3J1430 | J14 Temp.Transm./Thermocoup -Techn.Eval./Bid Tab | milestone | 0d | 2010-05-06 A | 2010-05-06 A | E3J1420 FF-11d | 100% |  |  |  |  | E3J1430 | E3J1430 | 86B | J14 | 0D | 999 | 2JD8710 | 200 | 200 | 055 | E |  | LND | 0 | E | J | EJ34 | LUZ2 | I | LND |  |  |  |
| E3J07B10 | J07B Switches&Alarms - Inquiry Spec. |  | 11d | 2010-05-10 A | 2010-05-26 A | F2570 | 100% |  |  |  |  | E3J07B10 | E3J07B10 | 86B | J07B | 0D | 999 | 2JD9490 | 200 | 200 | 055 | E | DEV | LEI | 0 | E | J | EJ33 | LUZ2 | I | LND |  |  |  |
| E3J0530 | J05 MPS/CMS -Techn.Eval./Bid Tab | milestone | 0d | 2010-05-12 A | 2010-05-12 A | E3J0520 FF-8d, E3J0515 SF | 100% |  |  |  |  | E3J0530 | E3J0530 | 86C | J05 | 0D | 999 | 2JD7520 | 200 | 200 | 055 | E |  | LND | 0 | E | J | EJ24 | LUZ2 | I | LND |  |  |  |
| HEJ37 | JB Location Dwgs | level of effort | 59d | 2010-05-25 A | 2010-08-13 A | EJ32171005 SS, EJ323140 SS, EJ321710 SS, EJ321718 SS, EJ323120 SS, EJ323110 SS | 100% |  |  |  |  | HEJ37 | HEJ37 | 86A |  | 0D | 999 |  | 200 | 200 | 070 | AD |  | LEI | L2 | E | J | EJ00 | LUZ2 | I | LND |  | 3A | Схемы расположения распределительных коробок |
| E3J0565 | J05 MPS/CMS - administration, techn. support |  | 180d | 2010-05-26 A | 2011-02-04 A | P3J05L FF-45d | 100% |  |  |  | TAP [3200 h] | E3J0565 | E3J0565 | 86B | J05 | 0D | 999 | 2JD7520 | 200 | 200 |  | E |  | LND | 0 | E | J | EJ35 | LUZ2 | PI | LND | 3200,00 |  |  |
| E3J13A30 | J13A Pressure Gauges -Techn.Eval./Bid Tab | milestone | 0d | 2010-05-28 A | 2010-05-28 A | E3J13A20 FF-8d, E3J13A15 SF | 100% |  |  |  |  | E3J13A30 | E3J13A30 | 86B | J13A | 0D | 999 | 2JD8480 | 200 | 200 | 055 | E |  | LND | 0 | E | J | EJ34 | LUZ2 | I | LND |  |  |  |
| E3J13C30 | J13C Pressure Switches -Techn.Eval./Bid Tab | milestone | 0d | 2010-05-28 A | 2010-05-28 A | E3J13C15 SF, E3J13C20 FF-8d | 100% |  |  |  |  | E3J13C30 | E3J13C30 | 86B | J13C | 0D | 999 | 2JD8960 | 200 | 200 | 055 | E |  | LND | 0 | E | J | EJ34 | LUZ2 | I | LND |  |  |  |
| E3J14B50 | J14B Temp. Gauges - Vendor dwgs approved | milestone | 0d | 2010-06-07 A | 2010-06-07 A | P3J14BL SF+30d, IMS-E-000210 FF | 100% |  |  |  |  | E3J14B50 | E3J14B50 | 86B | J14B | 0D | 999 | 2JD8700 | 200 | 200 |  | E |  | LND | 0 | E | J | EJ35 | LUZ2 | I | LND |  |  |  |
| E3J1850 | J18 Weighing for Vessels - Vendor dwgs approved | milestone | 0d | 2010-06-11 A | 2010-06-11 A | P3J18D FF+30d | 100% |  |  |  |  | E3J1850 | E3J1850 | 86B | J18 | 0D | 999 | J18 | 200 | 200 |  | E |  | LND | 0 | E | J | EJ35 | LUZ2 | I | LND |  |  |  |
| E3J1450 | J14 Temp.Transm./Thermocouple- Vendor dwgs appr. | milestone | 0d | 2010-06-21 A | 2010-06-21 A | P3J14L SF+30d | 100% |  |  |  |  | E3J1450 | E3J1450 | 86B | J14 | 0D | 999 | 2JD8710 | 200 | 200 |  | E |  | LND | 0 | E | J | EJ35 | LUZ2 | I | LND |  |  |  |
| EJ000195 | Participation 90% DSRV -upstream- 11/12/13/51-56 | level of effort | 15d | 2010-06-21 A | 2010-07-09 A | F4460 FF, EJ000190, F4460 SS | 100% |  |  |  |  | EJ000195 | EJ000195 | 86A |  | 0D | 999 |  | 200 | 200 | 070 | AD |  | LND | 1 | E | J | EJ00 | LUZ2 | I | LND |  | 3A |  |
| E3J07C20 | J07C Local Indicat. Panels - Techn. Eval./PO Spec |  | 48d | 2010-06-22 A | 2010-08-26 A | P3J07CB FS+25d | 100% |  |  |  |  | E3J07C20 | E3J07C20 | 86B | J07C | 0D | 999 | 2JD9500 | 200 | 200 | 055 | E |  | LEI | 0 | E | J | EJ34 | LUZ2 | I | LND |  |  |  |
| E3J1350 | J13 Diff.-/Press.Transm.(F/L) - Vendor dwgs appr. | milestone | 0d | 2010-06-24 A | 2010-06-24 A | P3J13L SF+30d, IMS-E-000210 FF | 100% |  |  |  |  | E3J1350 | E3J1350 | 86B | J13 | 0D | 999 | 2JD8840 | 200 | 200 |  | E |  | LND | 0 | E | J | EJ35 | LUZ2 | I | LND |  |  |  |
| E3J13B50 | J13B Pressure Transm. - Vendor dwgs appr. | milestone | 0d | 2010-06-24 A | 2010-06-24 A | IMS-E-000210 FF, P3J13BL SF+30d | 100% |  |  |  |  | E3J13B50 | E3J13B50 | 86B | J13B | 0D | 999 | 2JD8690 | 200 | 200 |  | E |  | LND | 0 | E | J | EJ35 | LUZ2 | I | LND |  |  |  |
| E3J04E50 | J04E Var.Area Flow.(Rotam.) - Vendor dwgs appr. | milestone | 0d | 2010-06-25 A | 2010-06-25 A | P3J04EL SF+30d | 100% |  |  |  |  | E3J04E50 | E3J04E50 | 86B | J04E | 0D | 999 | 2JD7330 | 200 | 200 |  | E |  | LND | 0 | E | J | EJ35 | LUZ2 | I | LND |  |  |  |
| E3J12A50 | J12A Radar Level M. - Vendor dwgs appr. | milestone | 0d | 2010-06-25 A | 2010-06-25 A | P3J12AL SF+30d | 100% |  |  |  |  | E3J12A50 | E3J12A50 | 86B | J12A | 0D | 999 | 2JD8440 | 200 | 200 |  | E |  | LND | 0 | E | J | EJ35 | LUZ2 | I | LND |  |  |  |
| E3J04I30 | J04I Ultrasonic Flowm. -Techn.Eval./Bid Tab | milestone | 0d | 2010-06-30 A | 2010-06-30 A | E3J04I15 SF, E3J04I20 FF-8d | 100% |  |  |  |  | E3J04I30 | E3J04I30 | 86B | J04I | 0D | 999 | 2JD8500 | 200 | 200 | 055 | E |  | LND | 0 | E | J | EJ34 | LUZ2 | I | LND |  |  |  |
| E3J14A30 | J14A Thermowell+Elements -Techn.Eval./Bid Tab | milestone | 0d | 2010-07-05 A | 2010-07-05 A | E3J14A20 FF-13d | 100% |  |  |  |  | E3J14A30 | E3J14A30 | 86B | J14A | 0D | 999 | 2JD8720 | 200 | 200 | 055 | E |  | LND | 0 | E | J | EJ34 | LUZ2 | I | LND |  |  |  |
| E3J1720 | J17 Instrument Cable - Techn. Eval./PO Spec |  | 199d | 2010-07-12 A | 2011-04-19 A | P3J17B FS+25d | 100% |  |  |  |  | E3J1720 | E3J1720 | 86B | J17 | 0D | 999 | 2JD9530 | 200 | 200 | 055 | E |  | LEI | 0 | E | J | EJ34 | LUZ2 | PI | LND |  |  |  |
| E3J07B20 | J07B Switches&Alarms - Techn. Eval./PO Spec |  | 51d | 2010-07-14 A | 2010-09-22 A | P3J07BB FS+25d | 100% |  |  |  |  | E3J07B20 | E3J07B20 | 86B | J07B | 0D | 999 | 2JD9490 | 200 | 200 | 055 | E |  | LEI | 0 | E | J | EJ34 | LUZ2 | I | LND |  |  |  |
| E3J13C50 | J13C Pressure Switches - Vendor dwgs appr. | milestone | 0d | 2010-07-15 A | 2010-07-15 A | P3J13CL SF+35d, IMS-E-000210 FF | 100% |  |  |  |  | E3J13C50 | E3J13C50 | 86B | J13C | 0D | 999 | 2JD8960 | 200 | 200 |  | E |  | LND | 0 | E | J | EJ35 | LUZ2 | I | LND |  |  |  |
| E3J13A50 | J13A Pressure Gauges - Vendor dwgs appr. | milestone | 0d | 2010-07-19 A | 2010-07-19 A | P3J13AL SF+30d, IMS-E-000210 FF | 100% |  |  |  |  | E3J13A50 | E3J13A50 | 86B | J13A | 0D | 999 | 2JD8480 | 200 | 200 |  | E |  | LND | 0 | E | J | EJ35 | LUZ2 | I | LND |  |  |  |
| A1EJ0025 | Revision Instrum. Function Engineering |  | 50d | 2010-08-10 A | 2010-10-18 A | A1EJ0020 | 100% |  |  |  |  | A1EJ0025 | A1EJ0025 | 86A |  | 0D | 999 |  | 200 |  |  | E |  | LND |  | E | J | EJ00 | LUZ2 | I | LND |  |  |  |
| E3J07C30 | J07C Local Indicat. Panels -Techn.Eval./Bid Tab | milestone | 0d | 2010-08-12 A | 2010-08-12 A | E3J07C20 FF-17d | 100% |  |  |  |  | E3J07C30 | E3J07C30 | 86B | J07C | 0D | 999 | 2JD9500 | 200 | 200 | 055 | E |  | LEI | 0 | E | J | EJ34 | LUZ2 | I | LND |  |  |  |
| HEJ80 | Loop Diagramms | level of effort | 70d | 2010-08-20 A | 2010-11-26 A | EJ801710 SS, EJ801718 SS, EJ803110 SS, EJ803120 SS, EJ803140 SS | 100% |  |  |  |  | HEJ80 | HEJ80 | 86A |  | 0D | 999 |  | 200 | 200 | 070 | AD |  | LEI | L2 | E | J | EJ00 | LUZ2 | I | LND |  | 3A | Контурные схемы |
| EJ000240 | Terminal Strip Lists |  | 119d | 2010-08-27 A | 2011-02-14 A | A1EJ0040 FF+10d | 100% |  |  |  | TAP [3840 h] | EJ000240 | EJ000240 | 86A |  | 0D | 999 |  | 200 |  |  | E |  | LND |  | E | J | EJ00 | LUZ2 | I | LND | 3840,00 |  |  |
| E3J1530 | J15 Winterization Enclosures -Techn.Eval./Bid Tab | milestone | 0d | 2010-08-30 A | 2010-08-30 A | E3J1520 FF-10d | 100% |  |  |  |  | E3J1530 | E3J1530 | 86B | J15 | 0D | 999 | 2JD9450 | 200 | 200 | 055 | E |  | LEI | 0 | E | J | EJ34 | LUZ2 | I | LND |  |  |  |
| EJ000202 | Participation 90% DSRV -upstream- 17 | level of effort | 10d | 2010-09-06 A | 2010-09-17 A | F4462 SS, EJ000195, F4462 FF | 100% |  |  |  |  | EJ000202 | EJ000202 | 86A |  | 0D | 999 |  | 200 | 200 | 070 | AD |  | LND | 1 | E | J | EJ00 | LUZ2 | I | LND |  | 3A |  |
| E3J14A50 | J14A Thermowell+Elements - Vendor dwgs appr. | milestone | 0d | 2010-09-06 A | 2010-09-06 A | P3J14AD FF+20d | 100% |  |  |  |  | E3J14A50 | E3J14A50 | 86B | J14A | 0D | 999 | 2JD8720 | 200 | 200 |  | E |  | LND | 0 | E | J | EJ35 | LUZ2 | I | LND |  |  |  |
| E3J07B30 | J07B Switches&Alarms -Techn.Eval./Bid Tab | milestone | 0d | 2010-09-09 A | 2010-09-09 A | E3J07B20 FF-10d | 100% |  |  |  |  | E3J07B30 | E3J07B30 | 86B | J07B | 0D | 999 | 2JD9490 | 200 | 200 | 055 | E |  | LEI | 0 | E | J | EJ34 | LUZ2 | I | LND |  |  |  |
| EJ000178 | Participation 60% DSRV -upstream- 10/14/53 | level of effort | 86d | 2010-09-20 A | 2011-01-20 A | F4048 SS, F4048 FF, EJ000202, F4045 FF, F4045 SS | 100% |  |  |  |  | EJ000178 | EJ000178 | 86A |  | 0D | 999 |  | 200 | 200 | 070 | AD |  | LND | 1 | E | J | EJ00 | LUZ2 | I | LND |  | 3A |  |
| E3J06F30 | J06F PLC Network -Techn.Eval./Bid Tab | milestone | 0d | 2010-09-22 A | 2010-09-22 A | E3J06F20 FF-7d | 100% |  |  |  |  | E3J06F30 | E3J06F30 | 86C | J06F | 0D | 999 | 2JD8450 | 200 | 200 | 055 | E |  | LND | 0 | E | J | EJ24 | LUZ2 | I | LND |  |  |  |
| E3J07C50 | J07C Local Indicat. Panels - Vendor dwgs approved | milestone | 0d | 2010-09-30 A | 2010-09-30 A | P3J07CL SF+35d | 100% |  |  |  |  | E3J07C50 | E3J07C50 | 86B | J07C | 0D | 999 | 2JD9500 | 200 | 200 |  | E |  | LEI | 0 | E | J | EJ35 | LUZ2 | I | LND |  |  |  |
| E3J04I50 | J04I Ultrasonic Flowm. - Vendor dwgs approved | milestone | 0d | 2010-10-15 A | 2010-10-15 A | P3J04IL SF+40d | 100% |  |  |  |  | E3J04I50 | E3J04I50 | 86B | J04I | 0D | 999 | 2JD8500 | 200 | 200 |  | E |  | LND | 0 | E | J | EJ35 | LUZ2 | I | LND |  |  |  |
| E3J07B50 | J07B Switches&Alarms - Vendor dwgs approved (main part) | milestone | 0d | 2010-10-22 A | 2010-10-22 A | P3J07BL SF+30d | 100% |  |  |  |  | E3J07B50 | E3J07B50 | 86B | J07B | 0D | 999 | 2JD9490 | 200 | 200 |  | E |  | LEI | 0 | E | J | EJ35 | LUZ2 | I | LND |  |  |  |
| E3J1730 | J17 Instrument Cable - Techn.Eval./Bid Tab | milestone | 0d | 2010-10-22 A | 2010-10-22 A | E3J1720 FF-10d | 100% |  |  |  |  | E3J1730 | E3J1730 | 86B | J17 | 0D | 999 | 2JD9530 | 200 | 200 | 055 | E |  | LEI | 0 | E | J | EJ34 | LUZ2 | PI | LND |  |  |  |
| E3J07A30 | J07A Sample Boards -Techn.Eval./Bid Tab | milestone | 0d | 2010-10-25 A | 2010-10-25 A | E3J07A20 FF-8d | 100% |  |  |  |  | E3J07A30 | E3J07A30 | 86B | J07A | 0D | 999 | 2JD9480 | 200 | 200 | 055 | E |  | LND | 0 | E | J | EJ34 | LUZ2 | I | LND |  |  |  |
| E3J12D30 | J12D Vibration Fork Level Switch-Techn.Eval./Bid Tab | milestone | 0d | 2010-10-26 A | 2010-10-26 A | E3J12D20 FF-8d | 100% |  |  |  |  | E3J12D30 | E3J12D30 | 86B | J12D | 0D | 999 | 2JD9190 | 200 | 200 | 055 | E |  | LEI | 0 | E | J | EJ34 | LUZ2 | I | LND |  |  |  |
| E3J0550 | J05 MPS/CMS - Vendor dwgs approved | milestone | 0d | 2010-11-11 A | 2010-11-11 A | P3J05D FF+60d | 100% |  |  |  |  | E3J0550 | E3J0550 | 86C | J05 | 0D | 999 | 2JD7520 | 200 | 200 |  | E |  | LND | 0 | E | J | EJ25 | LUZ2 | I | LND |  |  |  |
| E3J06F50 | J06F PLC Network - Vendor dwgs approved | milestone | 0d | 2010-11-30 A | 2010-11-30 A | IMS-E-000210 FF, P3J06FL SF+40d | 100% |  |  |  |  | E3J06F50 | E3J06F50 | 86B | J06F | 0D | 999 | 2JD8450 | 200 | 200 |  | E |  | LND | 0 | E | J | EJ35 | LUZ2 | I | LND |  |  |  |
| E3J07A50 | J07A Sample Boards - Vendor dwgs approved | milestone | 0d | 2010-12-13 A | 2010-12-13 A | P3J07AL SF+40d | 100% |  |  |  |  | E3J07A50 | E3J07A50 | 86B | J07A | 0D | 999 | 2JD9480 | 200 | 200 |  | E |  | LND | 0 | E | J | EJ35 | LUZ2 | I | LND |  |  |  |
| E3J12D50 | J12D Vibration Fork Level Switch - Vendor dwgs appr. | milestone | 0d | 2010-12-29 A | 2010-12-29 A | P3J12DL SF+35d | 100% |  |  |  |  | E3J12D50 | E3J12D50 | 86B | J12D | 0D | 999 | 2JD9190 | 200 | 200 |  | E |  | LEI | 0 | E | J | EJ35 | LUZ2 | I | LND |  |  |  |
| EJ000300 | Control Concept / Functional Design Chiller Unit |  | 35d | 2011-08-03 A | 2011-09-20 | E3M1750 FF+10d, E3M1820 SF, P030010 |  | 14d | 407.5d | 0d |  | EJ000240 | EJ000300 | 86A |  | 0D | 999 |  | 200 |  |  | E |  | LND |  | E | J | EJ00 | LUZ2 | I | LND |  |  |  |

Notes:
- E3J14B50: Expenses: 900A 0
- E3J1850: Expenses: 900A 0
- E3J1450: Expenses: 900A 0
- E3J1350: Expenses: 900A 0
- E3J13B50: Expenses: 900A 0
- E3J04E50: Expenses: 900A 0
- E3J12A50: Expenses: 900A 0
- E3J1720: Customer Problem: 11.01.11 B. RoЯberg - Vendor recommendation not yet / approved !
- E3J13C50: Expenses: 900A 0
- E3J13A50: Expenses: 900A 0
- E3J14A50: Expenses: 900A 0
- E3J04I50: Expenses: 900A 0
- E3J0550: Expenses: 900A 0
- E3J06F50: Expenses: 900A 0
- E3J07A50: Expenses: 900A 0
- E3J12D50: Expenses: 900A 0

| ID | WBS | Activity | Type | Duration | Start | Finish | Predecessors | Complete | Resources | TB26 Ressource Budget | UDF_SAVE ACTID | UDF_SAVE ACT ID | Department | Constr. Area | PMT-Area | PMT-Schedule Org | PMT-Discipline | PMT-Phase | PMT-Respons. | WBS Phase | WBS Discipline | WBS Type of Work | WBS Objects | IMS | UPT | Type of Work | Inquiry/Order No | PMT-Doc. Type | Zeigen/n. Zeigen | UDF_Actictity Name (Russia) | Pro Unit/DocCode |
| --- | --- | --- | --- | --- | --- | --- | --- | --- | --- | --- | --- | --- | --- | --- | --- | --- | --- | --- | --- | --- | --- | --- | --- | --- | --- | --- | --- | --- | --- | --- | --- |
|  | M | **M Mechanical - Rotating Equipment** |  |  | 2009-12-01 | 2010-12-30 |  |  |  |  |  |  |  |  |  |  |  |  |  |  |  |  |  |  |  |  |  |  |  |  |  |
| EM1000 |  | General Tasks & Coordinations DE Phase (TAM) |  | 273d | 2009-12-01 A | 2010-12-30 A | DE1000 | 100% | TAM [5696 h] | 5696,00 | EM1000 | EM1000 | 867 | 0D | 200 | 200 | 055 | E | LND | E | M | EM00 | LUZ2 | I | LND |  |  |  |  |  |  |
|  | R | **R Piping** |  |  | 2008-09-01 | 2011-06-10 |  |  |  |  |  |  |  |  |  |  |  |  |  |  |  |  |  |  |  |  |  |  |  |  |  |
| E3R0410 |  | R04 AG Gate Valves - Inquiry Spec. |  | 10d | 2008-09-01 A | 2008-09-12 A | A1010037 SF+3d | 100% |  |  | E3R0410 | E3R0410 | 873 | 0D | 200 | 200 | 055 | E | LND | E | R | ER23 | LUZ2 | PL | LND | R04 | 2AC2600 | DEV | 0 |  |  |
| E3R0610 |  | R06 AG Fittings CS - Inquiry Spec. |  | 8d | 2008-09-04 A | 2008-09-15 A | AD2060 FF-5d, A1010037 SF | 100% |  |  | E3R0610 | E3R0610 | 873 | 0D | 200 | 200 | 055 | E | LND | E | R | ER23 | LUZ2 | PL | LND | R06 | 2RE1820 | DEV | 0 |  |  |
| E3R06A10 |  | R06A AG Fittings SS - Inquiry Spec. |  | 8d | 2008-09-04 A | 2008-09-15 A | A1010037 SF, AD2060 FF-5d | 100% |  |  | E3R06A10 | E3R06A10 | 873 | 0D | 200 | 200 | 055 | E | LND | E | R | ER23 | LUZ2 | PL | LND | R06A | 2RE1830 | DEV | 0 |  |  |
| E3R06B10 |  | R06B AG Pipes CS - Inquiry Spec. |  | 10d | 2008-09-04 A | 2008-09-17 A | A1010037 SF, AD2060 FF-5d | 100% |  |  | E3R06B10 | E3R06B10 | 873 | 0D | 200 | 200 | 055 | E | LND | E | R | ER23 | LUZ2 | PL | LND | R06B | 2RE1800 | DEV | 0 |  |  |
| E3R06C10 |  | R06C AG Pipes SS - Inquiry Spec. |  | 9d | 2008-09-04 A | 2008-09-16 A | AD2060 FF-5d, A1010037 SF | 100% |  |  | E3R06C10 | E3R06C10 | 873 | 0D | 200 | 200 | 055 | E | LND | E | R | ER23 | LUZ2 | PL | LND | R06C | 2RE1810 | DEV | 0 |  |  |
| E3R06D10 |  | R06D AG Flanges CS/SS - Inquiry Spec. |  | 9d | 2008-09-04 A | 2008-09-16 A | A1010037 SF, AD2060 FF-5d | 100% |  |  | E3R06D10 | E3R06D10 | 873 | 0D | 200 | 200 | 055 | E | LND | E | R | ER23 | LUZ2 | PL | LND | R06D | 2RE1840 | DEV | 0 |  |  |
| A3KRB00100 |  | Piping Design Manual |  | 130d | 2008-10-07 A | 2009-04-17 A | AD2000 | 100% |  |  | A3KRB00100 | A3KRB00100 | 873 | 0D | 200 |  |  | E | LND | E | R | ER00 | LUZ2 | INS | LND |  |  |  |  |  |  |
| A1KR0015 |  | Special Parts for Piping |  | 583d | 2008-11-03 A | 2011-02-28 A | AD2020, E3R100 FF | 100% | TKR [7080 h] | 7080,00 | A1KR0015 | A1KR0015 | 873 | 0D | 200 |  |  | E | LND | E | R | ER00 | LUZ2 | PL | LND |  |  |  |  |  |  |
| A3KRB00110 |  | Nozzle Assembly Specification |  | 88d | 2008-12-08 A | 2009-04-17 A | A3KRB00100 FF | 100% |  |  | A3KRB00110 | A3KRB00110 | 873 | 0D | 200 |  |  | E | LND | E | R | ER00 | LUZ2 | INS | LND |  |  |  |  |  |  |
| E3R0210 |  | R02 UG GFK Pipes - Inquiry Spec. |  | 15d | 2009-01-05 A | 2009-01-23 A | A1010037 SS, A1010027 SS, AD2050 FF | 100% |  |  | E3R0210 | E3R0210 | 873 | 0D | 200 | 200 | 055 | E | LND | E | R | ER23 | LUZ2 | PL | LND | R02 | 2RE1350 | DEV | 0 |  |  |
| A1KL1133 |  | 2nd MTO Piping Material |  | 10d | 2009-01-12 A | 2009-01-23 A | AD2230 FS+10d | 100% |  |  | A1KL1133 | A1KL1133 | 873 | 0D | 200 |  |  | E | LND | E | R | ER00 | LUZ2 | PL | LND |  |  |  | L2 | 2-е MTO на материалы трубопроводов |  |
| A1KL1134 |  | 2nd MTO Piping Material | level of effort | 10d | 2009-01-12 A | 2009-01-23 A | A1KL1133 FF, A1KL1133 SS | 100% |  |  | A1KL1134 | A1KL1134 | 873 | 0D | 200 |  |  | E | LND | E | R | ER00 | LUZ2 |  | LND |  |  |  |  |  |  |
| E3R02A10 |  | R02A UG Cast Iron Pipes - Inquiry Spec. |  | 16d | 2009-01-12 A | 2009-02-02 A | A1010027 SS, AD2050 FF, A1010037 SS | 100% |  |  | E3R02A10 | E3R02A10 | 873 | 0D | 200 | 200 | 055 | E | LND | E | R | ER23 | LUZ2 | PL | LND | R02A | 2RE2240 | DEV | 0 |  |  |
| E3R02B10 |  | R02B HDPE Pipes - Inquiry Spec. |  | 16d | 2009-01-12 A | 2009-02-02 A | A1010037 SS, AD2050 FF, A1010027 SS | 100% |  |  | E3R02B10 | E3R02B10 | 873 | 0D | 200 | 200 | 055 | E | LND | E | R | ER23 | LUZ2 | PL | LND | R02B | 2RE2290 | DEV | 0 |  |  |
| A1KR1315 |  | Techn. Procurement&Dispo. Piping Mat. 2nd MTO |  | 15d | 2009-01-26 A | 2009-02-13 A | A1KL1133 | 100% |  |  | A1KR1315 | A1KR1315 | 873 | 0D | 200 |  |  | E | LND | E | R | ER00 | LUZ2 | PL | LND |  |  |  |  |  |  |
| F4020 |  | 1st MTO U/G-Piping/Valves |  | 15d | 2009-02-02 A | 2009-02-20 A | AD2230 FS+30d | 100% |  |  | F4020 | F4020 | 873 | 0D | 200 |  |  |  | LND | E | R | ER00 | LUZ2 | PI | LND |  |  |  | L2 | 1-е MTO на подземные трубопроводы/запорную арматуру | 91 |
| E3R02A20 |  | R02A UG Cast Iron Pipes - Techn. Eval./PO Spec |  | 294d | 2009-04-09 A | 2010-06-14 A | P3R02AB FS+30d | 100% | TKR [800 h] | 800,00 | E3R02A20 | E3R02A20 | 873 | 0D | 200 | 200 | 055 | E | LND | E | R | ER24 | LUZ2 | PL | LND | R02A | 2RE2240 |  | C5 |  |  |
| E3R02B20 |  | R02B HDPE Pipes - Techn. Eval./PO Spec |  | 468d | 2009-04-09 A | 2011-02-16 A | P3R02BB FS+30d | 100% |  |  | E3R02B20 | E3R02B20 | 873 | 0D | 200 | 200 | 055 | E | LND | E | R | ER24 | LUZ2 | PL | LND | R02B | 2RE2290 |  | 0 |  |  |
| E3R0220 |  | R02 UG GFK Pipes - Techn. Eval./PO Spec |  | 286d | 2009-04-15 A | 2010-06-04 A | P3R02B FS+50d | 100% | TKR [800 h] | 800,00 | E3R0220 | E3R0220 | 873 | 0D | 200 | 200 | 055 | E | LND | E | R | ER24 | LUZ2 | PL | LND | R02 | 2RE1350 |  | C5 |  |  |
| E3R0620 |  | R06 AG Fittings CS - Techn. Eval./PO Spec |  | 112d | 2009-09-17 A | 2010-02-26 A | P3R06B FS+10d | 100% | TKR [800 h] | 800,00 | E3R0620 | E3R0620 | 873 | 0D | 200 | 200 | 055 | E | LND | E | R | ER24 | LUZ2 | PL | LND | R06 | 2RE1820 |  | 0 |  |  |
| E3R06A20 |  | R06A AG Fittings SS - Techn. Eval./PO Spec |  | 136d | 2009-09-17 A | 2010-04-01 A | P3R06AB FS+10d | 100% | TKR [800 h] | 800,00 | E3R06A20 | E3R06A20 | 873 | 0D | 200 | 200 | 055 | E | LND | E | R | ER24 | LUZ2 | PL | LND | R06A | 2RE1830 |  | 0 |  |  |
| E3R06B20 |  | R06B AG Pipes CS - Techn. Eval./PO Spec |  | 108d | 2009-09-17 A | 2010-02-22 A | P3R06BB FS+10d | 100% | TKR [800 h] | 800,00 | E3R06B20 | E3R06B20 | 873 | 0D | 200 | 200 | 055 | E | LND | E | R | ER24 | LUZ2 | PL | LND | R06B | 2RE1800 |  | 0 |  |  |
| E3R06C20 |  | R06C AG Pipes SS - Techn. Eval./PO Spec |  | 137d | 2009-09-17 A | 2010-04-06 A | P3R06CB FS+10d | 100% | TKR [1200 h] | 1200,00 | E3R06C20 | E3R06C20 | 873 | 0D | 200 | 200 | 055 | E | LND | E | R | ER24 | LUZ2 | PL | LND | R06C | 2RE1810 |  | 0 |  |  |
| E3R06D20 |  | R06D AG Flanges CS/SS - Techn. Eval./PO Spec |  | 111d | 2009-09-17 A | 2010-02-25 A | P3R06DB FS+10d | 100% |  |  | E3R06D20 | E3R06D20 | 873 | 0D | 200 | 200 | 055 | E | LND | E | R | ER24 | LUZ2 | PL | LND | R06D | 2RE1840 |  | 0 |  |  |
| E3R0420 |  | R04 AG Gate Valves - Techn. Eval./PO Spec |  | 107d | 2009-10-05 A | 2010-03-09 A | P3R04B FS+15d, HER20 FF | 100% | TKR [320 h] | 320,00 | E3R0420 | E3R0420 | 873 | 0D | 200 | 200 | 055 | E | LND | E | R | ER24 | LUZ2 | PL | LND | R04 | 2AC2600 |  | 0 |  |  |
| HER36 |  | CAD Model Review 60% | level of effort | 108d | 2009-10-14 A | 2010-03-19 A | ER363110 SS, ER361710 FF, ER361201 FF, ER363120 SS | 100% |  |  | HER36 | HER36 | 873 | 0D | 200 |  |  | E | LND | E | R | ER00 | LUZ2 | 2 | LND |  |  |  | L2 | Сводный отчет по 60% модели CAD |  |
| E3A2512 |  | A25 Safety Showers - Inquiry Spec. Client approval |  | 49d | 2009-11-03 A | 2010-01-15 A | E3A2510 SS+15d | 100% |  |  | E3A2512 | E3A2512 | 873 | 0D | 200 | 200 | 055 | E | LND | E | R | ER23 | LUZ2 | 2 | LND | A25 | A25 | DEV | 0 |  |  |
| ER1000 |  | General Tasks & Coordinations DE Phase (Piping) |  | 328d | 2009-12-01 A | 2011-03-18 A | DE1000, E3R100 FF | 100% | TKR [7536 h] | 7536,00 | ER1000 | ER1000 | 873 | 0D | 200 |  |  | E | LND | E | R | ER00 | LUZ2 | PL | LND |  |  |  |  |  |  |
| ER000260 |  | Update Pipe Class Service Index |  | 40d | 2009-12-14 A | 2010-02-11 A | DE1000 FS+10d | 100% | TKR [640 h] | 640,00 | ER000260 | ER000260 | 873 | 0D | 200 |  |  | E | LND | E | R | ER00 | LUZ2 | PL | LND |  |  |  |  |  |  |
| ER000250 |  | Preparation BOM's |  | 299d | 2009-12-30 A | 2011-03-04 A | DE1000 FS+20d | 100% | TKR [4400 h] | 4400,00 | ER000250 | ER000250 | 873 | 0D | 200 |  |  | E | LND | E | R | ER00 | LUZ2 | PL | LND |  |  |  |  |  |  |
| A1KL1135 |  | 3rd MTO Piping Material |  | 10d | 2010-02-03 A | 2010-02-16 A | F4030 FS+50d, F4035 FS+50d | 100% |  |  | A1KL1135 | A1KL1135 | 873 | 0D | 200 |  |  | E | LND | E | R | ER00 | LUZ2 | PL | LND |  |  |  | L2 | 3-и MTO на материалы трубопроводов |  |
| E3R07A10 |  | R07A Standard Pipe Supp. - Inquiry Spec. |  | 15d | 2010-02-05 A | 2010-02-25 A | A1KL1135 FF, A1010032 SS, A1010033 SS+20d, A1010037 SS | 100% | TKR [480 h] | 480,00 | E3R07A10 | E3R07A10 | 873 | 0D | 200 | 200 | 055 | E | LND | E | R | ER23 | LUZ2 | PL | LND | R07A | 2RE2190 | DEV | 0 |  |  |
| E3R0630 |  | R06 AG Fittings CS - Techn. Eval./Bid Tab | milestone | 0d | 2010-02-11 A | 2010-02-11 A | E3R0620 FF-8d, E3R0615 SF | 100% |  |  | E3R0630 | E3R0630 | 873 | 0D | 200 | 200 | 055 | E | LND | E | R | ER24 | LUZ2 | PL | LND | R06 | 2RE1820 |  | 0 |  |  |
| E3R06D30 |  | R06D AG Flanges CS/SS - Techn. Eval./Bid Tab | milestone | 0d | 2010-02-16 A | 2010-02-16 A | E3R06D15 SF, E3R06D20 FF-8d | 100% |  |  | E3R06D30 | E3R06D30 | 873 | 0D | 200 | 200 | 055 | E | LND | E | R | ER24 | LUZ2 | PL | LND | R06D | 2RE1840 |  | 0 |  |  |
| E3R06B30 |  | R06B AG Pipes CS - Techn. Eval./Bid Tab | milestone | 0d | 2010-02-17 A | 2010-02-17 A | E3R06B15 SF, E3R06B20 FF-8d | 100% |  |  | E3R06B30 | E3R06B30 | 873 | 0D | 200 | 200 | 055 | E | LND | E | R | ER24 | LUZ2 | PL | LND | R06B | 2RE1800 |  | 0 |  |  |
| E3R0110 |  | R01 UG Post Ind. Valves - Inquiry Spec. (depends on client) |  | 136d | 2010-02-22 A | 2010-09-03 A | A1010027 SS, AD2050 FF, A1010037 SS | 100% | TKR [640 h] | 640,00 | E3R0110 | E3R0110 | 873 | 0D | 200 | 200 | 055 | E | LND | E | R | ER23 | LUZ2 | PL | LND | R01 | 2AC2690 | DEV | C5 |  |  |
| E3R0430 |  | R04 AG Gate Valves - Techn. Eval./Bid Tab | milestone | 0d | 2010-02-25 A | 2010-02-25 A | E3R0415 SF, E3R0420 FF-6d | 100% |  |  | E3R0430 | E3R0430 | 873 | 0D | 200 | 200 | 055 | E | LND | E | R | ER24 | LUZ2 | PL | LND | R04 | 2AC2600 |  | 0 |  |  |
| E3R0230 |  | R02 UG GFK Pipes - Techn. Eval./Bid Tab | milestone | 0d | 2010-03-11 A | 2010-03-11 A | E3R0220 FF-22d, E3R0215 SF | 100% |  |  | E3R0230 | E3R0230 | 873 | 0D | 200 | 200 | 055 | E | LND | E | R | ER24 | LUZ2 | PL | LND | R02 | 2RE1350 |  | 0 |  |  |
| E3R04A10 |  | R04A Piston RAM Valves - Inquiry Spec. |  | 15d | 2010-03-15 A | 2010-04-06 A | E3R0410 FS+380d | 100% |  |  | E3R04A10 | E3R04A10 | 873 | 0D | 200 | 200 | 055 | E | LND | E | R | ER23 | LUZ2 | PL | LND | R04A | 2AC5490 | DEV | 0 |  |  |
| E3R09B10 |  | R09B Air Manifolds - Inquiry Spec. |  | 18d | 2010-03-15 A | 2010-04-09 A | E3R03A10 FS+10d | 100% | TKR [480 h] | 480,00 | E3R09B10 | E3R09B10 | 873 | 0D | 200 | 200 | 055 | E | LND | E | R | ER23 | LUZ2 | PL | LND | R09B | 2RE2220 | DEV | 0 |  |  |
| E3R06C30 |  | R06C AG Pipes SS - Techn. Eval./Bid Tab | milestone | 0d | 2010-03-19 A | 2010-03-19 A | E3R06C20 FF-10d, E3R06C15 SF | 100% |  |  | E3R06C30 | E3R06C30 | 873 | 0D | 200 | 200 | 055 | E | LND | E | R | ER24 | LUZ2 | PL | LND | R06C | 2RE1810 |  | 0 |  |  |
| ER000265 |  | Check Manufacturer Documents / Certificates |  | 257d | 2010-03-23 A | 2011-03-25 A | P3R06BD FS+20d, DE1000 | 100% | TKR [11000 h] | 11000,00 | ER000265 | ER000265 | 873 | 0D | 200 |  |  | E | LND | E | R | ER00 | LUZ2 | PL | LND |  |  |  |  |  |  |
| E3R06A30 |  | R06A AG Fittings SS - Techn. Eval./Bid Tab | milestone | 0d | 2010-03-25 A | 2010-03-25 A | E3R06A15 SF, E3R06A20 FF-8d | 100% |  |  | E3R06A30 | E3R06A30 | 873 | 0D | 200 | 200 | 055 | E | LND | E | R | ER24 | LUZ2 | PL | LND | R06A | 2RE1830 |  | 0 |  |  |
| E3R07A20 |  | R07A Standard Pipe Supp. - Techn. Eval./PO Spec |  | 59d | 2010-04-19 A | 2010-07-12 A | P3R07AB FS+30d, HER20 FF | 100% | TKR [640 h] | 640,00 | E3R07A20 | E3R07A20 | 873 | 0D | 200 | 200 | 055 | E | LND | E | R | ER24 | LUZ2 | PL | LND | R07A | 2RE2190 |  | 0 |  |  |
| HER39 |  | CAD Model Review 90% | level of effort | 53d | 2010-04-26 A | 2010-07-09 A | ER391710 SS, ER391201 SS, ER393110 SS, ER393120 SS | 100% |  |  | HER39 | HER39 | 873 | 0D | 200 |  |  | E | LND | E | R | ER00 | LUZ2 | 3 | LND |  |  |  | L2 | Сводный отчет по 90% модели CAD |  |
| E3R04A20 |  | R04A Piston RAM Valves - Techn. Eval./PO Spec |  | 59d | 2010-05-25 A | 2010-08-13 A | P3R04AB FS+15d | 100% |  |  | E3R04A20 | E3R04A20 | 873 | 0D | 200 | 200 | 055 | E | LND | E | R | ER24 | LUZ2 | PL | LND | R04A | 2AC5490 |  | 0 |  |  |
| E3R02A30 |  | R02A UG Cast Iron Pipes - Techn. Eval./Bid Tab | milestone | 0d | 2010-05-27 A | 2010-05-27 A | E3R02A20 FF-7d, E3R02A15 SF | 100% |  |  | E3R02A30 | E3R02A30 | 873 | 0D | 200 | 200 | 055 | E | LND | E | R | ER24 | LUZ2 | PL | LND | R02A | 2RE2240 |  | 0 |  |  |
| E3R09B20 |  | R09B Air Manifolds - Techn. Eval./PO Spec |  | 61d | 2010-05-27 A | 2010-08-19 A | HER20 FF, A1010034 SF, E3R100 FF, A1KL1135 FF, P3R09BB FS+40d | 100% | TKR [1280 h] | 1280,00 | E3R09B20 | E3R09B20 | 873 | 0D | 200 | 200 | 055 | E | LND | E | R | ER24 | LUZ2 | PL | LND | R09B | 2RE2220 |  | 0 |  |  |
| E3R03A10 |  | R03A Bolting Material - Inquiry Spec. |  | 25d | 2010-06-21 A | 2010-07-23 A | A1010033 SS+20d, A1010032 SS, A1010037 SS | 100% | TKR [320 h] | 320,00 | E3R03A10 | E3R03A10 | 873 | 0D | 200 | 200 | 055 | E | LND | E | R | ER23 | LUZ2 | PL | LND | R03A | 2RE2610 | DEV | 0 |  |  |
| E3R07A30 |  | R07A Standard Pipe Supp. - Techn. Eval./Bid Tab | milestone | 0d | 2010-06-28 A | 2010-06-28 A | E3R07A20 FF-10d | 100% |  |  | E3R07A30 | E3R07A30 | 873 | 0D | 200 | 200 | 055 | E | LND | E | R | ER24 | LUZ2 | PL | LND | R07A | 2RE2190 |  | 0 |  |  |
| ER000255 |  | Final Engineering Documentation |  | 187d | 2010-06-28 A | 2011-03-18 A | ER1000 FF | 100% | TKR [480 h] | 480,00 | ER000255 | ER000255 | 873 | 0D | 200 |  |  | E | LND | E | R | ER00 | LUZ2 | PL | LND |  |  |  |  |  |  |
| E3R03B10 |  | R03B Gaskets - Inquiry Spec. |  | 19d | 2010-06-29 A | 2010-07-23 A | E3R03A10 FF, A1010037 SS, A1010033 SS+20d, A1010032 SS | 100% | TKR [320 h] | 320,00 | E3R03B10 | E3R03B10 | 873 | 0D | 200 | 200 | 055 | E | LND | E | R | ER23 | LUZ2 | PL | LND | R03B | 2RE2380 | DEV | 0 |  |  |
| E3A2510 |  | A25 Safety Showers - Inquiry Spec. |  | 50d | 2010-07-26 A | 2010-10-01 A | F1670 SS+415d | 100% |  |  | E3A2510 | E3A2510 | 873 | 0D | 200 | 200 | 055 | E | LND | E | R | ER23 | LUZ2 | 2 | LND | A25 | A25 | DEV | 0 |  |  |
| ER000270 |  | Final Manufacturer Documentation |  | 171d | 2010-07-27 A | 2011-03-25 A | P3R06BS1 FS+20d | 100% | TKR [2720 h] | 2720,00 | ER000270 | ER000270 | 873 | 0D | 200 |  |  | E | LND | E | R | ER00 | LUZ2 | PL | LND |  |  |  |  |  |  |
| E3R03A20 |  | R03A Bolting Material - Techn. Eval./PO Spec |  | 96d | 2010-07-30 A | 2010-12-13 A | HER20 FF, P3R03AB FS+20d, A1010034 SF | 100% | TKR [320 h] | 320,00 | E3R03A20 | E3R03A20 | 873 | 0D | 200 | 200 | 055 | E | LND | E | R | ER24 | LUZ2 | PL | LND | R03A | 2RE2610 |  | 0 |  |  |
| E3R04A30 |  | R04A Piston RAM Valves - Techn. Eval./Bid Tab | milestone | 0d | 2010-08-02 A | 2010-08-02 A | E3R04A20 FF-10d | 100% |  |  | E3R04A30 | E3R04A30 | 873 | 0D | 200 | 200 | 055 | E | LND | E | R | ER24 | LUZ2 | PL | LND | R04A | 2AC5490 |  | 0 |  |  |
| E3R09B30 |  | R09B Air Manifolds - Techn. Eval./Bid Tab | milestone | 0d | 2010-08-09 A | 2010-08-09 A | E3R09B20 FF-10d | 100% |  |  | E3R09B30 | E3R09B30 | 873 | 0D | 200 | 200 | 055 | E | LND | E | R | ER24 | LUZ2 | PL | LND | R09B | 2RE2220 |  | 0 |  |  |
| E3R03B20 |  | R03B Gaskets - Techn. Eval./PO Spec |  | 69d | 2010-09-06 A | 2010-12-10 A | A1010034 SF, P3R03BB FS+25d | 100% | TKR [480 h] | 480,00 | E3R03B20 | E3R03B20 | 873 | 0D | 200 | 200 | 055 | E | LND | E | R | ER24 | LUZ2 | PL | LND | R03B | 2RE2380 |  | 0 |  |  |
| E3R03A30 |  | R03A Bolting Material - Techn. Eval./Bid Tab | milestone | 0d | 2010-09-22 A | 2010-09-22 A | E3R03A20 FF-10d | 100% |  |  | E3R03A30 | E3R03A30 | 873 | 0D | 200 | 200 | 055 | E | LND | E | R | ER24 | LUZ2 | PL | LND | R03A | 2RE2610 |  | 0 |  |  |
| E3R09A10 |  | R09A Expansion Joints - Inquiry Spec. |  | 55d | 2010-09-27 A | 2010-12-13 A | E3R07B10 FF, A1010033 SF, A1010037 SS, A1010032 SS | 100% | TKR [640 h] | 640,00 | E3R09A10 | E3R09A10 | 873 | 0D | 200 | 200 | 055 | E | LND | E | R | ER23 | LUZ2 | PL | LND | R09A | R09A | DEV | 0 |  |  |
| E3R07B10 |  | R07B Special Pipe Supp. - Inquiry Spec. |  | 34d | 2010-09-28 A | 2010-11-12 A | P3R07AC FF+60d | 100% |  |  | E3R07B10 | E3R07B10 | 873 | 0D | 200 | 200 | 055 | E | LND | E | R | ER23 | LUZ2 | PL | LND | R07B | 2RE3370 | DEV | 0 |  |  |
| E3R0120 |  | R01 UG Post Ind. Valves - Techn. Eval./PO Spec |  | 82d | 2010-10-11 A | 2011-02-04 A | P3R01B FS+20d | 100% | TKR [320 h] | 320,00 | E3R0120 | E3R0120 | 873 | 0D | 200 | 200 | 055 | E | LND | E | R | ER24 | LUZ2 | PL | LND | R01 | 2AC2690 |  | 0 |  |  |
| E3A2520 |  | A25 Safety Showers - Techn. Eval./PO Spec |  | 163d | 2010-10-22 A | 2011-06-10 A | P3A25B FS+15d | 100% |  |  | E3A2520 | E3A2520 | 873 | 0D | 200 | 200 | 055 | E | LND | E | R | ER24 | LUZ2 | 2 | LND | A25 | A25 |  | 0 |  |  |
| E3R03B30 |  | R03B Gaskets - Techn. Eval./Bid Tab | milestone | 0d | 2010-11-22 A | 2010-11-22 A | E3R03B20 FF-15d | 100% |  |  | E3R03B30 | E3R03B30 | 873 | 0D | 200 | 200 | 055 | E | LND | E | R | ER24 | LUZ2 | PL | LND | R03B | 2RE2380 |  | 0 |  |  |
| E3R0130 |  | R01 UG Post Ind. Valves -Techn. Eval./Bid Tab | milestone | 0d | 2010-11-24 A | 2010-11-24 A | E3R0120 FF-8d | 100% |  |  | E3R0130 | E3R0130 | 873 | 0D | 200 | 200 | 055 | E | LND | E | R | ER24 | LUZ2 | PL | LND | R01 | 2AC2690 |  | 0 |  |  |
| E3R07B20 |  | R07B Special Pipe Supp. - Techn. Eval./PO Spec |  | 58d | 2010-12-27 A | 2011-03-17 A | P3R07BB FS+25d | 100% |  |  | E3R07B20 | E3R07B20 | 873 | 0D | 200 | 200 | 055 | E | LND | E | R | ER24 | LUZ2 | PL | LND | R07B | 2RE3370 |  | 0 |  |  |
| E3R09A20 |  | R09A Expansion Joints - Techn. Eval./PO Spec |  | 86d | 2011-01-20 A | 2011-05-19 A | P3R09AB FS+20d, A1KL1135 FF | 100% | TKR [640 h] | 640,00 | E3R09A20 | E3R09A20 | 873 | 0D | 200 | 200 | 055 | E | LND | E | R | ER24 | LUZ2 | PL | LND | R09A | R09A |  | 0 |  |  |

| ID | WBS | Activity | Type | Duration | Start | Finish | Predecessors | Complete | Resources | UDF_SAVE ACTID | UDF_SAVE ACT ID | Department | Type of Work | Constr. Area | Inquiry/Order No | PMT-Area | PMT-Schedule Org | PMT-Discipline | PMT-Phase | PMT-Respons. | Zeigen/n. Zeigen | WBS Phase | WBS Discipline | WBS Type of Work | WBS Objects | IMS | UPT | PMT-Doc. Type | TB26 Ressource Budget |
| --- | --- | --- | --- | --- | --- | --- | --- | --- | --- | --- | --- | --- | --- | --- | --- | --- | --- | --- | --- | --- | --- | --- | --- | --- | --- | --- | --- | --- | --- |
| E3R02B30 |  | R02B HDPE Pipes - Techn. Eval./Bid Tab | milestone | 0d | 2011-02-08 A | 2011-02-08 A | E3R02B20 FF-7d, E3R02B15 SF | 100% |  | E3R02B30 | E3R02B30 | 873 | R02B | 0D | 2RE2290 | 200 | 200 | 055 | E | LND | 0 | E | R | ER24 | LUZ2 | PL | LND |  |  |
| E3R07B30 |  | R07B Special Pipe Supp. - Techn. Eval./Bid Tab | milestone | 0d | 2011-03-04 A | 2011-03-04 A | E3R07B20 FF-10d | 100% |  | E3R07B30 | E3R07B30 | 873 | R07B | 0D | 2RE3370 | 200 | 200 | 055 | E | LND | 0 | E | R | ER24 | LUZ2 | PL | LND |  |  |
| E3R0150 |  | R01 UG Post Ind. Valves - Vendor dwgs approved | milestone | 0d | 2011-03-07 A | 2011-03-07 A | P3R01L SS+30d | 100% |  | E3R0150 | E3R0150 | 873 | R01 | 0D | 2AC2690 | 200 | 200 | 055 | E | LND | 0 | E | R | ER25 | LUZ2 | PL | LND | DFA |  |
| A1KL1137 |  | Last MTO Piping Material |  | 10d | 2011-03-29 A | 2011-04-11 A | E3R100 FF, ER491740 FF, ER491760 FF, ER491736 FF | 100% |  | A1KL1137 | A1KL1137 | 873 |  | 0D |  | 200 |  |  | E | LND | L2 | E | R | ER00 | LUZ2 | 1 | LND |  |  |
| A1KL1138 |  | Last MTO Piping Material | level of effort | 10d | 2011-03-29 A | 2011-04-11 A | A1KL1137 SS, A1KL1137 FF | 100% |  | A1KL1138 | A1KL1138 | 873 |  | 0D |  | 200 |  |  | E | LND | M1 | E | R | ER00 | LUZ2 | 1 | LND |  |  |
| E3R09A30 |  | R09A Expansion Joints - Techn. Eval./Bid Tab | milestone | 0d | 2011-05-06 A | 2011-05-06 A | E3R09A20 FF-10d | 100% |  | E3R09A30 | E3R09A30 | 873 | R09A | 0D | R09A | 200 | 200 | 055 | E | LND | 0 | E | R | ER24 | LUZ2 | PL | LND |  |  |
| E3A2530 |  | A25 Safety Showers -Techn. Eval./Bid Tab F | milestone | 0d | 2011-06-02 A | 2011-06-02 A | E3A2520 FF-7d | 100% |  | E3A2530 | E3A2530 | 873 | A25 | 0D | A25 | 200 | 200 | 055 | E | LND | 0 | E | R | ER24 | LUZ2 | 2 | LND |  |  |
|  | S | **S Safety & Environment** |  |  | 2008-07-04 | 2011-05-02 |  |  |  |  |  |  |  |  |  |  |  |  |  |  |  |  |  |  |  |  |  |  |  |
| ES100030 |  | Noise Level Calculation and Report |  | 50d | 2008-07-04 A | 2008-09-11 A | AD2240 | 100% |  | ES100030 | ES100030 | 871 |  | 0D |  |  |  |  | E | LND |  | E | S | 0000 | LUZ2 | 1 | LND |  |  |
| ES100010 |  | Fire Protection Plan 2nd Issue |  | 10d | 2008-08-18 A | 2008-08-29 A | AD2240, ES100250 FF | 100% |  | ES100010 | ES100010 | 871 |  | 0D |  |  |  |  | E | LND |  | E | S | 0000 | LUZ2 | 1 | LND |  |  |
| ES100020 |  | Area Classification Plan (Ex-Zone) 2nd Issue |  | 10d | 2008-08-18 A | 2008-08-29 A | ES100010 | 100% |  | ES100020 | ES100020 | 871 |  | 0D |  |  |  |  | E | LND |  | E | S | 0000 | LUZ2 | 1 | LND |  |  |
| E3S0610 |  | S06 Sprinkler System - Inquiry Spec. |  | 14d | 2008-09-15 A | 2008-10-02 A | F4430 FF, A1MECS01 SF-5d | 100% |  | E3S0610 | E3S0610 | 871 | S06 | 0D | 2SI1740 | 200 | 200 | 055 | E | LND | 0 | E | S | ES23 | LUZ2 | 1 | LND | DEV |  |
| E3S0710 |  | S07 Deluge System - Inquiry Spec. |  | 14d | 2008-09-15 A | 2008-10-02 A | F4430 FF, A1010027, AD1340 | 100% |  | E3S0710 | E3S0710 | 871 | S07 | 0D | 2SI1730 | 200 | 200 | 055 | E | LND | 0 | E | S | ES23 | LUZ2 | 1 | LND | DEV |  |
| E3S0110 |  | S01 Safety Relief Valves - Inquiry Spec. |  | 12d | 2008-09-22 A | 2008-10-08 A | AD1220 | 100% |  | E3S0110 | E3S0110 | 871 | S01 | 0D | 2SI1760 | 200 | 200 | 055 | E | LND | 0 | E | S | ES23 | LUZ2 | SA | LND | DEV |  |
| E3S0210 |  | S02 Rupture Disks - Inquiry Spec. |  | 12d | 2008-09-22 A | 2008-10-08 A | A1MECS01 SS+5d | 100% |  | E3S0210 | E3S0210 | 871 | S02 | 0D | 2SI1750 | 200 | 200 | 055 | E | LND | 0 | E | S | ES23 | LUZ2 | 1 | LND | DEV |  |
| E3S0510 |  | S05 Gas Exting. Syst. - Inquiry Spec. |  | 20d | 2008-10-01 A | 2008-10-29 A | A1MECS01 SS | 100% |  | E3S0510 | E3S0510 | 871 | S05 | 0D | 2SI1770 | 200 | 200 | 055 | E | LND | 0 | E | S | ES23 | LUZ2 | 1 | LND | DEV |  |
| E3S0810 |  | S08 Hydrants/Monitors - Inquiry Spec. |  | 9d | 2008-12-01 A | 2008-12-11 A | ER440000 SF-15d, F4430, A1010027 | 100% |  | E3S0810 | E3S0810 | 871 | S08A | 0D | 2SI1810 | 200 | 200 | 055 | E | LND | 0 | E | S | ES23 | LUZ2 | 1 | LND | DEV |  |
| ES100000 |  | HAZOP Package Units Part I |  | 5d | 2008-12-08 A | 2008-12-12 A | E3M0340, E3M0440 | 100% |  | ES100000 | ES100000 | 871 |  | 0D |  |  |  |  | E | LND |  | E | S | ES10 | LUZ2 | 1 | LND |  |  |
| E3S0120 |  | S01 Safety Relief Valves - Techn. Eval./PO Spec |  | 293d | 2009-01-19 A | 2010-03-17 A | P3S01B FS+30d | 100% | TAS [1280 h] | E3S0120 | E3S0120 | 871 | S01 | 0D | 2SI1760 | 200 | 200 | 055 | E | LND | 0 | E | S | ES24 | LUZ2 | 1 | LND |  | 1280,00 |
| HES20E |  | Techn. Evalualtions/PO Spec's Eqpt. | level of effort | 467d | 2009-01-19 A | 2010-11-23 A | E3S0220 SS, E3S0820 SS, E3S0120 SS | 100% |  | HES20E | HES20E | 871 |  | 0D |  |  |  |  | E | LND | L2 | E | S | 0000 | LUZ2 | 1 | LND |  |  |
| E3S0220 |  | S02 Rupture Disks - Techn. Eval./PO Spec |  | 290d | 2009-02-23 A | 2010-04-20 A | P3S02B FS+20d | 100% | TAS [640 h] | E3S0220 | E3S0220 | 871 | S02 | 0D | 2SI1750 | 200 | 200 | 055 | E | LND | 0 | E | S | ES24 | LUZ2 | 1 | LND |  | 640,00 |
| ES100120 |  | Safety Requirements f. Flare Pckg. Spec. A18 |  | 44d | 2009-03-23 A | 2009-05-27 A | E3A1805 | 100% |  | ES100120 | ES100120 | 871 | A18 | 0D | 2DD0330 |  |  |  | E | LND | FL | E | S | 0000 | LUZ2 | 1 | LND |  |  |
| ES100000A |  | HAZOP SMOC's |  | 2d | 2009-03-26 A | 2009-03-27 A | E3U1040, ES100030 FF, ES100000 | 100% |  | ES100000A | ES100000A | 871 |  | 0D |  |  |  |  | E | LND |  | E | S | ES10 | LUZ2 | 1 | LND |  |  |
| E3S0230 |  | S02 Rupture Disks -Techn. Eval./Bid Tab | milestone | 0d | 2009-03-27 A | 2009-03-27 A | E3S0215 SF, E3S0220 SF-10d | 100% |  | E3S0230 | E3S0230 | 871 | S02 | 0D | 2SI1750 | 200 | 200 | 055 | E | LND | 0 | E | S | ES24 | LUZ2 | 1 | LND |  |  |
| E3S0130 |  | S01 Safety Relief Valves -Techn. Eval./Bid Tab | milestone | 0d | 2009-04-01 A | 2009-04-01 A | E3S0120 SF, E3S0115 SF | 100% |  | E3S0130 | E3S0130 | 871 | S01 | 0D | 2SI1760 | 200 | 200 | 055 | E | LND | 0 | E | S | ES24 | LUZ2 | 1 | LND |  |  |
| ES100000B |  | HAZOP Package Units Part II |  | 3d | 2009-04-02 A | 2009-04-06 A | E3U0240, E3M0240, ES100000A | 100% |  | ES100000B | ES100000B | 871 |  | 0D |  |  |  |  | E | LND |  | E | S | ES10 | LUZ2 | 1 | LND |  |  |
| ES100130 |  | Verificat. Reliefing Syst. based on Flare Propo. |  | 40d | 2009-08-07 A | 2009-10-01 A | E3A1810 SS+71d | 100% |  | ES100130 | ES100130 | 871 |  | 0D |  |  |  |  | E | LND | FL | E | S | 0000 | LUZ2 | 1 | LND |  |  |
| E3S1010 |  | S10 Flame Arrestors - Inquiry Spec. |  | 15d | 2009-09-07 A | 2009-09-25 A | A1MECS01 FS+20d, F4430 | 100% |  | E3S1010 | E3S1010 | 871 | S10 | 0D | 2SI1880 | 200 | 200 | 055 | E | LND | 0 | E | S | ES23 | LUZ2 | 1 | LND | DEV |  |
| E3S0820 |  | S08A Hydrants - Techn. Eval./PO Spec |  | 188d | 2009-09-16 A | 2010-06-17 A | P3S08B FS+185d | 100% | TAS [320 h] | E3S0820 | E3S0820 | 871 | S08A | 0D | 2SI1810 | 200 | 200 | 055 | E | LND | 0 | E | S | ES24 | LUZ2 | 1 | LND |  | 320,00 |
| E3S0910 |  | S09 Minor FF Equipment - Inquiry Spec. |  | 15d | 2009-09-28 A | 2009-10-16 A | A1MECS01 FS+20d, F4430 | 100% | TAS | E3S0910 | E3S0910 | 871 | S09 | 0D | 2SI1890 | 200 | 200 | 055 | E | LND | 0 | E | S | ES23 | LUZ2 | 1 | LND | DEV | 0,00 |
| ES000165 |  | 60% DSRV -downstream- | level of effort | 7d | 2009-10-19 A | 2009-10-27 A | F4035 FF, F4035 SS | 100% |  | ES000165 | ES000165 | 871 |  | 0D |  |  |  |  | E | LND |  | E | S | 0000 | LUZ2 | 1 | LND |  |  |
| E3S0620 |  | S06 Sprinkler System - Techn. Eval./PO Spec |  | 94d | 2009-10-29 A | 2010-03-16 A | EC45314005 SS+23d, P3C00E FS+20d, P3S06B FS+40d | 100% | TAS [1280 h] | E3S0620 | E3S0620 | 871 | S06 | 0D | 2SI1740 | 200 | 200 | 055 | E | LND | 0 | E | S | ES24 | LUZ2 | 1 | LND |  | 1280,00 |
| E3S0720 |  | S07 Deluge System - Techn. Eval./PO Spec |  | 87d | 2009-10-29 A | 2010-03-05 A | P3C00E FS+20d, P3S06C FF, P3S07B FS+20d | 100% | TAS [1280 h] | E3S0720 | E3S0720 | 871 | S07 | 0D | 2SI1730 | 200 | 200 | 055 | E | LND | 0 | E | S | ES24 | LUZ2 | 1 | LND |  | 1280,00 |
| HES20S |  | Techn. Evalualtions/PO Spec's Systems | level of effort | 87d | 2009-10-29 A | 2010-03-05 A | E3S0520 SS, E3S0620 SS, E3S0720 FF | 100% |  | HES20S | HES20S | 871 |  | 0D |  |  |  |  | E | LND | L2 | E | S | 0000 | LUZ2 | 1 | LND |  |  |
| ES000160 |  | 60% DSRV -upstream- 11/12/13/51/55-56 | level of effort | 12d | 2009-11-02 A | 2009-11-17 A | F4030 SS, F4030 FF | 100% |  | ES000160 | ES000160 | 871 |  | 0D |  |  |  |  | E | LND |  | E | S | 0000 | LUZ2 | 1 | LND |  |  |
| ES100140 |  | Pressure drop calculations |  | 186d | 2009-11-02 A | 2010-07-30 A | E3A1840 FF, ES100230 SS | 100% | TAS [3200 h] | ES100140 | ES100140 | 871 |  | 0D |  |  |  |  | E | LND | FL | E | S | 0000 | LUZ2 | 1 | LND |  | 3200,00 |
| ES100230 |  | Explosion- / Gasdetection Plan (update) |  | 350d | 2009-11-11 A | 2011-03-31 A | F4040 FF, ES100010 | 100% | TAS [1600 h] | ES100230 | ES100230 | 871 |  | 0D |  |  |  |  | E | LND |  | E | S | 0000 | LUZ2 | 1 | LND |  | 1600,00 |
| E3S0520 |  | S05 Gas Exting. Syst. - Techn. Eval./PO Spec |  | 249d | 2009-11-16 A | 2010-11-10 A | P3S05B FS+45d, E3S0550 FF+10d, EC45170005 SF+5d, EC45314005 SF+90d, P3C00E FS+20d, EC45161005 SF | 100% | TAS [1280 h] | E3S0520 | E3S0520 | 871 | S05 | 0D | 2SI1770 | 200 | 200 | 055 | E | LND | 0 | E | S | ES24 | LUZ2 | 1 | LND |  | 1280,00 |
| ES1000 |  | General Task & Coordination (Safety) |  | 337d | 2009-12-01 A | 2011-03-31 A | E3S100 FF, ES100240 FF, ES100230 FF, ES100210 FF, DE1000 | 100% | TAS [7360 h] | ES1000 | ES1000 | 871 |  | 0D |  |  |  |  | E | LND |  | E | S | 0000 | LUZ2 | 1 | LND |  | 7360,00 |
| ES100240 |  | Safety Fire Fighting Engineering |  | 315d | 2009-12-07 A | 2011-03-07 A | E3S0620 FF+30d | 100% | TAS [2240 h] | ES100240 | ES100240 | 871 |  | 0D |  |  |  |  | E | LND | FL | E | S | 0000 | LUZ2 | 1 | LND |  | 2240,00 |
| ES100300 |  | PHA Finalisation and Final Report |  | 299d | 2009-12-14 A | 2011-02-18 A | ES1000 FF | 100% | TAS [3216 h] | ES100300 | ES100300 | 871 |  | 0D |  |  |  |  | E | LND | FL | E | S | 0000 | LUZ2 | 1 | LND |  | 3216,00 |
| E3S1020 |  | S10 Flame Arrestors - Techn. Eval./PO Spec |  | 50d | 2009-12-17 A | 2010-03-02 A | E3S100 FF, HES20E FF, P3S10B FS+50d | 100% | TAS [160 h] | E3S1020 | E3S1020 | 871 | S10 | 0D | 2SI1880 | 200 | 200 | 055 | E | LND | 0 | E | S | ES24 | LUZ2 | 1 | LND |  | 160,00 |
| E3S0920 |  | S09 Minor FF Equipment - Techn. Eval./PO Spec |  | 234d | 2009-12-21 A | 2010-11-24 A | P3S09B FS+80d, E3S100 FF, HES20E FF | 100% | TAS [320 h] | E3S0920 | E3S0920 | 871 | S09 | 0D | 2SI1890 | 200 | 200 | 055 | E | LND | 0 | E | S | ES24 | LUZ2 | 1 | LND |  | 320,00 |
| E3S1030 |  | S10 Flame Arrestors -Techn. Eval./Bid Tab | milestone | 0d | 2010-01-20 A | 2010-01-20 A | E3S1020 FF-10d | 100% |  | E3S1030 | E3S1030 | 871 | S10 | 0D | 2SI1880 | 200 | 200 | 055 | E | LND | 0 | E | S | ES24 | LUZ2 | 1 | LND |  |  |
| E3S0630 |  | S06 Sprinkler System -Techn. Eval./Bid Tab | milestone | 0d | 2010-01-25 A | 2010-01-25 A | E3S0615 SF, E3S0620 FF-10d | 100% |  | E3S0630 | E3S0630 | 871 | S06 | 0D | 2SI1740 | 200 | 200 | 055 | E | LND | 0 | E | S | ES24 | LUZ2 | 1 | LND |  |  |
| E3S0730 |  | S07 Deluge System -Techn. Eval./Bid Tab | milestone | 0d | 2010-01-25 A | 2010-01-25 A | E3S0715 SF, E3S0720 FF-10d | 100% |  | E3S0730 | E3S0730 | 871 | S07 | 0D | 2SI1730 | 200 | 200 | 055 | E | LND | 0 | E | S | ES24 | LUZ2 | 1 | LND |  |  |
| E3S08B30 |  | S08B Monitors -Techn. Eval./Bid Tab | milestone | 0d | 2010-01-27 A | 2010-01-27 A | E3S08B20 FF-10d | 100% |  | E3S08B30 | E3S08B30 | 871 | S08B | 0D | 2SI1930 | 200 | 200 | 055 | E | LND | 0 | E | S | ES24 | LUZ2 | 1 | LND |  |  |
| ES100000C |  | HAZOP Package Units Part IV |  | 28d | 2010-02-15 A | 2010-03-24 A | ES100000B | 100% |  | ES100000C | ES100000C | 871 |  | 0D |  |  |  |  | E | LND |  | E | S | ES10 | LUZ2 | 1 | LND |  |  |
| ES100250 |  | Other Fire Fighting Documents & Lists |  | 193d | 2010-02-22 A | 2010-11-24 A | E3S0920 FF | 100% | TAS [1280 h] | ES100250 | ES100250 | 871 |  | 0D |  |  |  |  | E | LND | FL | E | S | 0000 | LUZ2 | 1 | LND |  | 1280,00 |
| ES000170 |  | 60% DSRV -upstream- 15/16/17/52,54 | level of effort | 15d | 2010-03-01 A | 2010-03-19 A | F4040 FF, F4040 SS | 100% |  | ES000170 | ES000170 | 871 |  | 0D |  |  |  |  | E | LND |  | E | S | 0000 | LUZ2 | 1 | LND |  |  |
| E3S08B20 |  | S08B Monitors - Techn. Eval./PO Spec |  | 57d | 2010-03-08 A | 2010-05-31 A | E3S0820 SS+15d, P3S08B | 100% | TAS [320 h] | E3S08B20 | E3S08B20 | 871 | S08B | 0D | 2SI1930 | 200 | 200 | 055 | E | LND | 0 | E | S | ES24 | LUZ2 | 1 | LND |  | 320,00 |
| ES100260 |  | Noise Allocation Report |  | 164d | 2010-04-06 A | 2010-11-24 A | E3S100 FF, ES100250 FF, ES100030 | 100% | TAS [1200 h] | ES100260 | ES100260 | 871 |  | 0D |  |  |  |  | E | LND | FL | E | S | 0000 | LUZ2 | 1 | LND |  | 1200,00 |
| ES100110 |  | Operation Manual |  | 265d | 2010-04-20 A | 2011-05-02 A | A1CF0240 SS, A1CF0240 FF-10d | 100% | TAS [1280 h] | ES100110 | ES100110 | 871 |  | 0D |  |  |  |  | E | LND |  | E | S | 0000 | LUZ2 | 1 | LND |  | 1280,00 |
| ES000190 |  | 90% DSRV -downstream- | level of effort | 10d | 2010-04-26 A | 2010-05-07 A | F9250 FF, F9250 SS | 100% |  | ES000190 | ES000190 | 871 |  | 0D |  |  |  |  | E | LND |  | E | S | 0000 | LUZ2 | 1 | LND |  |  |
| ES100210 |  | Environmental Emission Plan and List (update) |  | 239d | 2010-04-26 A | 2011-03-31 A | DE1000 FS+25d, ES100050 SS+5d | 100% | TAS [480 h] | ES100210 | ES100210 | 871 |  | 0D |  |  |  |  | E | LND |  | E | S | 0000 | LUZ2 | 1 | LND |  | 480,00 |
| E3S0830 |  | S08A Hydrants -Techn. Eval./Bid Tab | milestone | 0d | 2010-06-04 A | 2010-06-04 A | E3S0820 FF-8d | 100% |  | E3S0830 | E3S0830 | 871 | S08A | 0D | 2SI1810 | 200 | 200 | 055 | E | LND | 0 | E | S | ES24 | LUZ2 | 1 | LND |  |  |
| ES100050 |  | Escape Route Plan |  | 201d | 2010-06-21 A | 2011-03-31 A | F4460 FF+15d, ES100010 | 100% | TAS [640 h] | ES100050 | ES100050 | 871 |  | 0D |  |  |  |  | E | LND |  | E | S | 0000 | LUZ2 | 1 | LND |  | 640,00 |
| ES100000D |  | HAZOP Flare |  | 3d | 2010-08-03 A | 2010-08-05 A | E3A1850, ES100000C | 100% |  | ES100000D | ES100000D | 871 |  | 0D |  |  |  |  | E | LND |  | E | S | ES10 | LUZ2 | 1 | LND |  |  |
| E3S0930 |  | S09 Minor FF Equipment -Techn. Eval./Bid Tab | milestone | 0d | 2010-10-14 A | 2010-10-14 A | E3S0920 FF-10d | 100% |  | E3S0930 | E3S0930 | 871 | S09 | 0D | 2SI1890 | 200 | 200 | 055 | E | LND | 0 | E | S | ES24 | LUZ2 | 1 | LND |  |  |
| E3S0530 |  | S05 Gas Exting. Syst. -Techn. Eval./Bid Tab | milestone | 0d | 2010-10-26 A | 2010-10-26 A | E3S0520 FF-8d, E3S0515 SF | 100% |  | E3S0530 | E3S0530 | 871 | S05 | 0D | 2SI1770 | 200 | 200 | 055 | E | LND | 0 | E | S | ES24 | LUZ2 | 1 | LND |  |  |

Notes:
- E3R0150: Expenses: 900A 0
- A1KL1137: UDF_Actictity Name (Russia): Последние MTO на материалы трубопроводов
- A1KL1138: UDF_Actictity Name (Russia): Последний MTO Трубный материал
- HES20E: UDF_Actictity Name (Russia): Технические анализы/спецификации заказов на поставку, оборудование
- HES20S: UDF_Actictity Name (Russia): Технические анализы/спецификации заказов на поставку, системы

| ID | WBS | Activity | Type | Duration | Start | Finish | Predecessors | Complete | Constraint | Resources | TB26 Ressource Budget | UDF_SAVE ACTID | UDF_SAVE ACT ID | Department | Constr. Area | PMT-Area | PMT-Schedule Org | PMT-Discipline | PMT-Phase | PMT-Doc. Type | PMT-Respons. | Zeigen/n. Zeigen | WBS Phase | WBS Discipline | WBS Objects | IMS | UPT | WBS Type of Work | UDF_Actictity Name (Russia) |
| --- | --- | --- | --- | --- | --- | --- | --- | --- | --- | --- | --- | --- | --- | --- | --- | --- | --- | --- | --- | --- | --- | --- | --- | --- | --- | --- | --- | --- | --- |
|  | Q | **Q Quality Planning/ Qualtity Assurance** |  |  | 2009-12-01 | 2011-02-28 |  |  |  |  |  |  |  |  |  |  |  |  |  |  |  |  |  |  |  |  |  |  |  |
| EQ1000 |  | General Tasks & Coordinations DE Phase (Quality) |  | 314d | 2009-12-01 A | 2011-02-28 A | DE1000 | 100% |  | QM-Q [63512 h] | 63512,00 | EQ1000 | EQ1000 | 87C | 0D | 000 | 200 | 400 | P | DEV | LND | 0 | E | Q | LUZ2 | OTH | LND |  |  |
|  | LUZ1 | **LUZ1 Lutz Kern - Procurement** |  |  | 2007-12-10 | 2011-05-13 |  |  |  |  |  |  |  |  |  |  |  |  |  |  |  |  |  |  |  |  |  |  |  |
|  | L | **L Plant Design** |  |  | 2007-12-10 | 2011-05-13 |  |  |  |  |  |  |  |  |  |  |  |  |  |  |  |  |  |  |  |  |  |  |  |
| IMS-E-000070 |  | Piping Design | level of effort | 830d | 2007-12-10 A | 2011-03-31 A | F1810 SS, F1000 SS | 100% |  |  |  | IMS-E-000070 | IMS-E-000070 | 876 | 0D | 200 |  |  | E |  | LND |  | E | L | LUZ1 | 1 | IMS | 0000 |  |
| A1KL1130A |  | Nozzle Orientation Reactors |  | 71d | 2008-07-21 A | 2008-10-28 A | E3ALL160 FF | 100% |  |  |  | A1KL1130A | A1KL1130A | 876 | 0D | 200 |  |  | E |  | LND |  | E | L | LUZ1 | ME | LND | 0000 |  |
| A1KL1130B |  | Nozzle Orientation Purge Columns |  | 9d | 2008-12-09 A | 2008-12-19 A | E3ALL240, AD2230 FF+1d | 100% |  |  |  | A1KL1130B | A1KL1130B | 876 | 0D | 200 |  |  | E |  | LND |  | E | L | LUZ1 | ME | LND | 0000 |  |
| HEL30 |  | Final Nozzle Orientations Main Equipment | level of effort | 199d | 2008-12-09 A | 2009-09-25 A | A1KL1130C SS, A1KL1130B SS | 100% |  |  |  | HEL30 | HEL30 | 876 | 0D | 200 |  |  | E |  | LND | L2 | E | L | LUZ1 | I | LND | 0000 | Окончательная ориентация штуцеров основного оборудования |
| A1KL0020 |  | Detail Piping Design in Piperacks (w/o CA53) |  | 398d | 2009-01-12 A | 2010-08-10 A | AD2200, AD2240 FS-25d | 100% |  |  |  | A1KL0020 | A1KL0020 | 876 | 0D | 200 |  |  | E |  | LND |  | E | L | LUZ1 | PL | LND | 0000 |  |
| A1KL1130C |  | Nozzle Orientation Gas Exp. Bag Filter |  | 50d | 2009-01-26 A | 2009-04-03 A | AD2230 FF+10d, E3A0840 | 100% |  |  |  | A1KL1130C | A1KL1130C | 876 | 0D | 200 |  |  | E |  | LND |  | E | L | LUZ1 | ME | LND | 0000 |  |
| A1KL1130E |  | Nozzle Orientation Reactor Overhead Condenser |  | 50d | 2009-01-26 A | 2009-04-03 A | AD2230 FF+10d, HEL30 FF, E3A04A40 | 100% |  |  |  | A1KL1130E | A1KL1130E | 876 | 0D | 200 |  |  | E |  | LND |  | E | L | LUZ1 | ME | LND | 0000 |  |
| A1KL0025 |  | Pipe Stress Analysis |  | 194d | 2009-02-09 A | 2009-11-12 A | A1KL0020 SS+20d | 100% |  |  |  | A1KL0025 | A1KL0025 | 872 | 0D | 200 |  |  | E |  | LND |  | E | L | LUZ1 | PL | LND | 0000 |  |
| A1KL1140 |  | Nozzle Orientation Minor Equipment |  | 159d | 2009-02-10 A | 2009-09-25 A | HEL30 FF | 100% |  |  |  | A1KL1140 | A1KL1140 | 876 | 0D | 200 |  |  | E |  | LND | L2 | E | L | LUZ1 | ME | LND | 0000 | Ориентация штуцеров второстепенного оборудования |
| A3KLD00110 |  | Plot Plan (Process Plant) issue for Design | milestone | 0d | 2009-02-14 A | 2009-02-14 A | AD2240 FF+10d | 100% |  |  |  | A3KLD00110 | A3KLD00110 | 876 | 0D | 200 |  |  | E |  | LND | L2 | E | L | LUZ1 | INS | LND | 0000 | Генплан (технологический участок), выпуск для проектирования |
| A1KL0010 |  | Detail Piping Design in Construction Areas |  | 439d | 2009-02-27 A | 2010-11-24 A | A1KL0025 SS+15d, AD1220, A1KL0020 SS | 100% |  |  |  | A1KL0010 | A1KL0010 | 876 | 0D | 200 |  |  | E |  | LNI |  | E | L | LUZ1 | PL | LND | 0000 |  |
| A1KL0030 |  | Fitting Dimensions Inliner/C.Valves available | milestone | 0d | 2009-10-19 A | 2009-10-19 A | F4030 SF-10d | 100% |  |  |  | A1KL0030 | A1KL0030 | 876 | 0D | 200 |  |  | E |  | LND |  | E | L | LUZ1 | PL | LND | 0000 |  |
| EL1000 |  | General Tasks & Coordinations DE Phase (PLant Design) |  | 337d | 2009-12-01 A | 2011-03-31 A | DE1000 | 100% |  | TKK [41280 h] | 41280,00 | EL1000 | EL1000 | 876 | 0D | 200 |  |  | E |  | LND |  | E | L | LUZ1 | PL | LND | 0000 |  |
| EL1020 |  | 3D Modelling / CAD Administration |  | 337d | 2009-12-01 A | 2011-03-31 A | DE1000 | 100% |  | TKK [158040 h] | 158040,00 | EL1020 | EL1020 | 876 | 0D | 200 |  |  | E |  | LND |  | E | L | LUZ1 | PL | LND | 0000 |  |
| EL1010 |  | Drawings, MTO's, General activities |  | 328d | 2009-12-14 A | 2011-03-31 A | IMS-E-000070 FF, DE1000 FS+10d | 100% |  | TKK [25600 h] | 25600,00 | EL1010 | EL1010 | 876 | 0D | 200 |  |  | E |  | LND |  | E | L | LUZ1 | PL | LND | 0000 |  |
| IMS-E-000110 |  | Release Isometrics AG-Piping (incl. EQP Iso's) for Construction | level of effort | 204d | 2010-07-21 A | 2011-05-05 A | ER49313005 SS, ER493130 SS, ER49311005 SS, ER493140 SS, ER495401 SS, ER495103 SS, ER493110 SS, A1KL0010 FF+25d, ER493120 SS, ER495102 SS, ER49312005 SS, ER49314005 SS | 100% |  |  |  | IMS-E-000110 | IMS-E-000110 | 876 | 0D | 200 |  |  | E |  | LND |  | E | L | LUZ1 | 5 | IMS | 0000 |  |
| A1KL1130F |  | Nozzle Orientation Flare KO Drum |  | 68d | 2010-07-28 A | 2010-10-29 A | E3A02A50 FF+5d, E3A02A15 | 100% |  |  |  | A1KL1130F | A1KL1130F | 876 | 0D | 200 |  |  | E |  | LND |  | E | L | LUZ1 | ME | LND | 0000 |  |
| IMS-E-000100 |  | Release Isometrics UG-Piping for Construction | level of effort | 31d | 2010-09-24 A | 2010-11-05 A | ER443110 SS, ER443120 SS, ER443130 SS | 100% |  |  |  | IMS-E-000100 | IMS-E-000100 | 876 | 0D | 200 |  |  | E |  | LND |  | E | L | LUZ1 | 4 | IMS | 0000 |  |
| EL1030 |  | Building Internal Drainage Pipeline Systems |  | 113d | 2010-10-11 A | 2011-03-21 A | ER443130 SS | 100% |  |  |  | EL1030 | EL1030 | 876 | 0D | 200 |  |  | E |  | LND |  | E | L | LUZ1 | ME | LND | 0000 |  |
| EL1040 |  | Pipeline List |  | 75d | 2010-12-03 A | 2011-03-21 A | EL1030 FF | 100% |  |  |  | EL1040 | EL1040 | 876 | 0D | 200 |  |  | E |  | LND |  | E | L | LUZ1 | ME | LND | 0000 |  |
| ER291200 |  | Plotplan Issue CA12 | milestone | 0d | 2010-12-06 A | 2010-12-06 A | F4460 | 100% | finish on 2010-12-06 |  |  | ER291200 | ER291200 | 876 | 0D | 200 |  |  | E |  | LEI |  | E | L | LUZ1 | 5 | LND | ER29 |  |
| ER291300 |  | Plotplan Issue CA13 | milestone | 0d | 2010-12-06 A | 2010-12-06 A | F4460 | 100% | finish on 2010-12-06 |  |  | ER291300 | ER291300 | 876 | 0D | 200 |  |  | E |  | LEI |  | E | L | LUZ1 | 5 | LND | ER29 |  |
| ER293100 |  | Plotplan Issue CA31 | milestone | 0d | 2011-02-23 A | 2011-02-23 A | ER291300 FF+55d | 100% |  |  |  | ER293100 | ER293100 | 876 | 0D | 200 |  |  | E |  | LND |  | E | L | LUZ1 | 5 | LND | ER29 |  |
| ER291000 |  | Plotplan Issue CA10 | milestone | 0d | 2011-03-11 A | 2011-03-11 A | ER291100 FF | 100% |  |  |  | ER291000 | ER291000 | 876 | 0D | 200 |  |  | E |  | LEI |  | E | L | LUZ1 | 5 | LND | ER29 |  |
| ER291100 |  | Plotplan Issue CA11 | milestone | 0d | 2011-03-11 A | 2011-03-11 A | F4460 | 100% | finish on 2011-03-11 |  |  | ER291100 | ER291100 | 876 | 0D | 200 |  |  | E |  | LEI |  | E | L | LUZ1 | 5 | LND | ER29 |  |
| ER291400 |  | Plotplan Issue CA14 | milestone | 0d | 2011-03-31 A | 2011-03-31 A | ER291100 FF+15d | 100% |  |  |  | ER291400 | ER291400 | 876 | 0D | 200 |  |  | E |  | LEI |  | E | L | LUZ1 | 5 | LND | ER29 |  |
| ER291500 |  | Plotplan Issue CA15 | milestone | 0d | 2011-03-31 A | 2011-03-31 A | ER291100 FF+15d | 100% |  |  |  | ER291500 | ER291500 | 876 | 0D | 200 |  |  | E |  | LEI |  | E | L | LUZ1 | 5 | LND | ER29 |  |
| ER291700 |  | Plotplan Issue CA17 | milestone | 0d | 2011-03-31 A | 2011-03-31 A | ER291100 FF+15d | 100% |  |  |  | ER291700 | ER291700 | 876 | 0D | 200 |  |  | E |  | LEI |  | E | L | LUZ1 | 5 | LND | ER29 |  |
| ER291810 |  | Concept Plotplan Issue CA18 | milestone | 0d | 2011-05-13 A | 2011-05-13 A | E3M1810 SF, E3M1720 SF, P030010 FS+24d, E3A02D10 SF | 100% |  |  |  | ER291700 | ER291810 | 876 | 0D | 200 |  |  | E |  | LEI |  | E | L | LUZ1 | 5 | LND | ER29 |  |

Notes:
- IMS-E-000070: P3 Activity Log Info: CAD-Pipeclasses & Pipesupports (PDS) / 3D-Model of Equipment / 3D-Model of Lines / Plot Plan Status F (AFD)
- A1KL1130A: P3 Activity Log Info: freeze after 30%
- A1KL1130B: P3 Activity Log Info: freeze after 30%
- HEL30: P3 Activity Log Info: freeze after 30%
- A1KL0020: P3 Activity Log Info: CAD-Pipeclasses & Pipesupports (PDS) 3D-Model of / Equipment 3D-Model of Lines Plot Plan Status F (AFD)
- A1KL1130C: P3 Activity Log Info: freeze after 30%
- A1KL1130E: P3 Activity Log Info: freeze after 30%
- A1KL0025: P3 Activity Log Info: CAD-Pipeclasses & Pipesupports (PDS) / 3D-Model of Equipment / 3D-Model of Lines / Plot Plan Status F (AFD)
- A1KL1140: P3 Activity Log Info: freeze after 30%
- A3KLD00110: P3 Activity Log Info: Status F
- A1KL0030: P3 Activity Log Info: deleted
- IMS-E-000110: P3 Activity Log Info: CAD-Pipeclasses & Pipesupports (PDS) / 3D-Model of Equipment / 3D-Model of Lines / Plot Plan Status F (AFD)
- A1KL1130F: P3 Activity Log Info: freeze after 30%
- IMS-E-000100: P3 Activity Log Info: CAD-Pipeclasses & Pipesupports (PDS) / 3D-Model of Equipment / 3D-Model of Lines / Plot Plan Status F (AFD)
- EL1030: P3 Activity Log Info: freeze after 30%
- EL1040: P3 Activity Log Info: freeze after 30%

| ID | WBS | Activity | Type | Duration | Start | Finish | Predecessors | Complete | Resources | TB26 Ressource Budget | UDF_SAVE ACTID | UDF_SAVE ACT ID | Department | Constr. Area | Inquiry/Order No | PMT-Area | PMT-Schedule Org | PMT-Discipline | PMT-Phase | PMT-Stage | PMT-Respons. | Zeigen/n. Zeigen | WBS Phase | WBS Discipline | WBS Type of Work | WBS Objects | IMS | UPT | UDF_Actictity Name (Russia) | Type of Work | PMT-Doc. Type |
| --- | --- | --- | --- | --- | --- | --- | --- | --- | --- | --- | --- | --- | --- | --- | --- | --- | --- | --- | --- | --- | --- | --- | --- | --- | --- | --- | --- | --- | --- | --- | --- |
|  | 0000 | **0000 Generals - all CA's** |  |  | 2008-07-14 | 2011-04-21 |  |  |  |  |  |  |  |  |  |  |  |  |  |  |  |  |  |  |  |  |  |  |  |  |  |
|  | P | **P Process** |  |  | 2010-04-01 | 2010-10-29 |  |  |  |  |  |  |  |  |  |  |  |  |  |  |  |  |  |  |  |  |  |  |  |  |  |
| ETF00100 |  | Prep. Precommissioning TO documentation |  | 148d | 2010-04-01 A | 2010-10-29 A | ETM00110 FF+5d | 100% | CB [3160 h] | 3160,00 | ETF00100 | ETF00100 | 924 | 0D | 999 | 200 | 200 | 002 | E | 3B | LND | 1 | E | P | 0000 | 0000 | 1 | LND |  |  |  |
|  | L | **L Plant Design** |  |  | 2009-02-02 | 2010-08-11 |  |  |  |  |  |  |  |  |  |  |  |  |  |  |  |  |  |  |  |  |  |  |  |  |  |
| ER440000 |  | CA00 General - UG-Piping Detail Engineering |  | 384d | 2009-02-02 A | 2010-08-11 A | A1010027 SS, AD2230, AD2210, F4035 FF+90d, A3KLD00110 FS-10d, F4030 FF+90d | 100% |  |  | ER440000 | ER440000 | 876 | 0D |  | 200 |  |  | E |  | LND | C5 | E | L | ER44 | 0000 | 4 | LND |  |  |  |
|  | C | **C Civil** |  |  | 2008-07-14 | 2011-04-21 |  |  |  |  |  |  |  |  |  |  |  |  |  |  |  |  |  |  |  |  |  |  |  |  |  |
| E3C110 |  | Layout Drwgs Buildings AFC | level of effort | 578d | 2008-07-14 A | 2010-10-29 A | EC443110 SS | 100% |  |  | E3C110 | E3C110 | 87A | 0D |  |  |  |  | E |  | LND | M1 | E | C |  | 0000 | ar | LND | Компоновочные чертежи зданий AFC |  |  |
| EC48100 |  | CA00 General - Fire Safety Report |  | 43d | 2008-11-17 A | 2009-01-22 A | F2760 | 100% |  |  | EC48100 | EC48100 | 87A | 0D |  | 200 |  |  | AD |  | PMT |  | E | C | EC00 | 0000 | de | LND |  |  |  |
| EC300000 |  | CA00 General - UG-Systems Detail Engineering | level of effort | 376d | 2009-02-02 A | 2010-07-30 A | ER440000 SS | 100% |  |  | EC300000 | EC300000 | 87A | 0D |  | 200 |  |  | E |  | LND |  | E | C | EC30 | 0000 | cq | LND |  |  |  |
| IMS-E-000170 |  | Building Layout Drwgs AFC | level of effort | 276d | 2009-08-24 A | 2010-09-24 A | EC45311005 SS, EC45312005 SS, EC45313005 SS, EC45314005 SS | 100% |  |  | IMS-E-000170 | IMS-E-000170 | 87A | 0D |  |  |  |  | E |  | LND |  | E | C |  | 0000 | ar | IMS | Чертежи свай AFC |  |  |
| IMS-E-000130 |  | Piling Drwgs AFC | level of effort | 384d | 2009-09-07 A | 2011-03-14 A | EC153110 SS, EC153140 SS, EC153130 SS | 100% |  |  | IMS-E-000130 | IMS-E-000130 | 87A | 0D |  |  |  |  | E |  | LND | M1 | E | C |  | 0000 | PI | IMS | Чертежи свай AFC |  |  |
| IMS-E-000150 |  | Foundations & Underground Drwgs AFC | level of effort | 302d | 2009-09-21 A | 2010-11-30 A | EC28120105 SS, EC28311003 SS, EC283115 SS | 100% |  |  | IMS-E-000150 | IMS-E-000150 | 87A | 0D |  |  |  |  | E |  | LND |  | E | C |  | 0000 | cq | IMS | Чертежи свай AFC |  |  |
| IMS-E-000140 |  | Precast Drwgs AFC | level of effort | 397d | 2009-09-28 A | 2011-04-21 A | EC28311004 SS | 100% |  |  | IMS-E-000140 | IMS-E-000140 | 87A | 0D |  |  |  |  | E |  | LND |  | E | C |  | 0000 | PRE | IMS | Чертежи свай AFC |  |  |
| ETC00100 |  | Prep. Piling Turnover documentation |  | 43.5d | 2009-12-02 A | 2010-02-05 A | DE1000 | 100% | TKB-B [320 h] | 320,00 | ETC00100 | ETC00100 | 87A | 0D |  | 200 | 200 | 002 | E | 3B | LND | 1 | E | C | 0000 | 0000 | 00 | LND |  |  |  |
| ETC00110 |  | Prep. Civil Turnover documentation |  | 249.5d | 2010-01-05 A | 2010-12-28 A | DE1000 | 100% | TKB-B [320 h] | 320,00 | ETC00110 | ETC00110 | 87A | 0D |  | 200 | 200 | 002 | E | 3B | LND | 1 | E | C | 0000 | 0000 | 00 | LND |  |  |  |
| IMS-E-000160 |  | Piperacks Concrete Structure Drwgs AFC | level of effort | 181d | 2010-08-09 A | 2011-04-21 A | EC28510305, EC28510205 | 100% |  |  | IMS-E-000160 | IMS-E-000160 | 87A | 0D |  |  |  |  | E |  | LND |  | E | C |  | 0000 | cs | IMS | Чертежи свай AFC |  |  |
|  | H | **H HVAC** |  |  | 2009-08-31 | 2010-12-17 |  |  |  |  |  |  |  |  |  |  |  |  |  |  |  |  |  |  |  |  |  |  |  |  |  |
| E3H0150 |  | HVAC Detail Engineering - Eval./PO |  | 104.39d | 2009-08-31 A | 2010-01-29 A | F1700, F1620, EH30314005 SS, E3H0110 FF+10d, AD2230 | 100% | TKB-H [320 h] | 320,00 | E3H0150 | E3H0150 | 87C | 0D | H01 | 000 | 200 | 400 | P |  | LND | 0 | E | H | EH13 | 0000 | OTH | LND |  | H01 | DEV |
| E3H0120 |  | HVAC Construction - Eval./PO |  | 256d | 2009-12-14 A | 2010-12-17 A | P3C02D2 FF, P3C02CB SS | 100% | TKB-H [480 h] | 480,00 | E3H0120 | E3H0120 | 87C | 0D | H01 | 000 | 200 | 400 | P |  | LND | 0 | E | H | EH13 | 0000 | OTH | LND |  | H01 | DEV |
| ETH00100 |  | Prep. HVAC,plumbing,sanitary Turnover documentation |  | 135.5d | 2010-04-13 A | 2010-10-21 A | DE1000 | 100% | TKB-H [560 h] | 560,00 | ETH00100 | ETH00100 | 87C | 0D |  | 200 | 200 | 002 | E | 3B | LND | 1 | E | H | 0000 | 0000 | 00 | LND |  |  |  |
|  | R | **R Piping** |  |  | 2010-09-24 | 2010-11-05 |  |  |  |  |  |  |  |  |  |  |  |  |  |  |  |  |  |  |  |  |  |  |  |  |  |
| HER44 |  | U/G Piping Isometrics Release (Press.Systems) | level of effort | 31d | 2010-09-24 A | 2010-11-05 A | ER441600 SS, ER443110 SS, ER441700 SS | 100% |  |  | HER44 | HER44 | 876 | 0D |  | 200 | 200 |  | E |  | LND | C5 | E | R | ER00 | 0000 | 4 | LND | Выпуск изометрических чертежей подземных трубопроводов |  |  |
|  | E | **E Electrical** |  |  | 2008-12-01 | 2011-03-21 |  |  |  |  |  |  |  |  |  |  |  |  |  |  |  |  |  |  |  |  |  |  |  |  |  |
| EE000050 |  | Electrical Load Balance - 2nd Issue |  | 47d | 2008-12-01 A | 2009-02-10 A | AD1720 FF | 100% |  |  | EE000050 | EE000050 | 874 | 0D |  |  |  |  | E |  | LND |  | E | E | EE00 | 0000 | de | LND |  |  |  |
| EE000060 |  | Electrical Short Circuit Calculation |  | 205d | 2008-12-01 A | 2009-09-25 A | EE000050 FF+20d | 100% |  |  | EE000060 | EE000060 | 874 | 0D |  |  |  |  | E |  | LND |  | E | E | EE00 | 0000 | de | LND |  |  |  |
| EE000040 |  | Input for OBCE, Issue of BOQ's |  | 20d | 2009-01-05 A | 2009-01-30 A | F9040 | 100% |  |  | EE000040 | EE000040 | 874 | 0D |  |  |  |  | E |  | LND |  | E | E | EE00 | 0000 | de | LND |  |  |  |
| EE000150 |  | One Line Diagram - 2nd Issue |  | 17d | 2009-01-19 A | 2009-02-10 A | F1940 FF, EE000050 FF | 100% |  |  | EE000150 | EE000150 | 874 | 0D |  |  |  |  | E |  | LND |  | E | E | EE00 | 0000 | E | LND |  |  |  |
| EE000165 |  | Participation 60% DSRV -downstream- | level of effort | 7d | 2009-10-19 A | 2009-10-27 A | F4035 FF, F4035 SS | 100% |  |  | EE000165 | EE000165 | 874 | 0D |  |  |  |  | E |  | LND |  | E | E | EE00 | 0000 | E | LND |  |  |  |
| EE000160 |  | Participation 60% DSRV -upstream- 11/12/13/51/55-56 | level of effort | 12d | 2009-11-02 A | 2009-11-17 A | EE000165, F4030 FF, F4030 SS | 100% |  |  | EE000160 | EE000160 | 874 | 0D |  |  |  |  | E |  | LND |  | E | E | EE00 | 0000 | E | LND |  |  |  |
| EE1000 |  | General Task & Coordination DE Phase |  | 324d | 2009-12-01 A | 2011-03-14 A | DE1000, EE500140 FF, IMS-E-000190 FF | 100% | TAE [12800 h] | 12800,00 | EE1000 | EE1000 | 874 | 0D |  |  |  |  | E |  | LND |  | E | E | EE00 | 0000 | E | LND |  |  |  |
| EE000220 |  | Interface and Signal Lists - final |  | 315d | 2009-12-21 A | 2011-03-21 A | IMS-E-000190 FF, EE000100 FF | 100% | TAE [8000 h] | 8000,00 | EE000220 | EE000220 | 874 | 0D |  |  |  |  | E |  | LND |  | E | E | EE00 | 0000 | E | LND |  |  |  |
| ETE00100 |  | Prep. Electrical Turnover documentation |  | 111d | 2010-02-22 A | 2010-07-30 A | DE1000 | 100% | TAE [1808 h] | 1808,00 | ETE00100 | ETE00100 | 874 | 0D |  | 200 | 200 | 002 | E | 3B | LND | 1 | E | E | EE00 | 0000 | 00 | LND |  |  |  |
| EE000170 |  | Participation 60% DSRV -upstream- 15/16/17/52,54 | level of effort | 15d | 2010-03-01 A | 2010-03-19 A | F4040 SS, EE000160, F4040 FF | 100% |  |  | EE000170 | EE000170 | 874 | 0D |  |  |  |  | E |  | LEI |  | E | E | EE00 | 0000 | E | LND |  |  |  |
| EE000190 |  | Participation 90% DSRV -downstream- | level of effort | 10d | 2010-04-26 A | 2010-05-07 A | EE000170, F9250 SS, F9250 FF | 100% |  |  | EE000190 | EE000190 | 874 | 0D |  |  |  |  | E |  | LND |  | E | E | EE00 | 0000 | E | LND |  |  |  |
| EE000290 |  | Final Detail Documentation Electrical |  | 126d | 2010-06-07 A | 2010-11-30 A | EE000220 SS, EE360260 FF+45d, IMS-E-000190 FF, EE000060 | 100% | TAE [5248 h] | 5248,00 | EE000290 | EE000290 | 874 | 0D |  |  |  |  | E |  | LND |  | E | E | EE00 | 0000 | E | LND |  |  |  |
| EE000195 |  | Participation 90% DSRV -upstream- 11/12/13/51-56 | level of effort | 15d | 2010-06-21 A | 2010-07-09 A | F4460 FF, F4460 SS | 100% |  |  | EE000195 | EE000195 | 874 | 0D |  |  |  |  | E |  | LEI |  | E | E | EE00 | 0000 | E | LND |  |  |  |
| EE000200 |  | Participation 90% DSRV -upstream- 17 | level of effort | 10d | 2010-09-06 A | 2010-09-17 A | EE000195, F4462 SS, F4462 FF | 100% |  |  | EE000200 | EE000200 | 874 | 0D |  |  |  |  | E |  | LEI |  | E | E | EE00 | 0000 | E | LND |  |  |  |
| EE000175 |  | Participation 60% DSRV -upstream- 10/14/53 | level of effort | 86d | 2010-09-20 A | 2011-01-20 A | F4045 FF, F4048 SS, F4048 FF, F4045 SS, EE000200 | 100% |  |  | EE000175 | EE000175 | 874 | 0D |  |  |  |  | E |  | LEI |  | E | E | EE00 | 0000 | E | LND |  |  |  |

Notes:
- HER44: P3 Activity Log Info: HOLD (Piping Design Stoped)

| ID | WBS | Activity | Type | Duration | Start | Finish | Predecessors | Complete | Resources | TB26 Ressource Budget | UDF_SAVE ACTID | UDF_SAVE ACT ID | Department | Constr. Area | Pro Unit/DocCode | PMT-Area | PMT-Schedule Org | PMT-Discipline | PMT-Phase | PMT-Stage | PMT-Respons. | Zeigen/n. Zeigen | WBS Phase | WBS Discipline | WBS Type of Work | WBS Objects | IMS | UPT | Inquiry/Order No | Type of Work |
| --- | --- | --- | --- | --- | --- | --- | --- | --- | --- | --- | --- | --- | --- | --- | --- | --- | --- | --- | --- | --- | --- | --- | --- | --- | --- | --- | --- | --- | --- | --- |
|  | J | **J Instrumentation** |  |  | 2010-05-03 | 2010-11-02 |  |  |  |  |  |  |  |  |  |  |  |  |  |  |  |  |  |  |  |  |  |  |  |  |
| ETJ00100 |  | Prep. Instrumentation/ Control system Turnover documentation |  | 130d | 2010-05-03 A | 2010-11-02 A | DE1000 | 100% | TAP [1680 h] | 1680,00 | ETJ00100 | ETJ00100 | 86A | 0D | 999 | 200 | 200 | 002 | E | 3B | LND | 1 | E | J | EJ00 | 0000 | 00 | LND |  |  |
|  | S | **S Safety & Environment** |  |  | 2010-04-06 | 2010-08-13 |  |  |  |  |  |  |  |  |  |  |  |  |  |  |  |  |  |  |  |  |  |  |  |  |
| ETS00100 |  | Prep. Safety equipment TO documentation |  | 92d | 2010-04-06 A | 2010-08-13 A | DE1000 | 100% | TAS [616 h] | 616,00 | ETS00100 | ETS00100 | 871 | 0D |  | 200 | 200 | 002 | E | 3B | LND | 1 | E | S | 0000 | 0000 | SA | LND |  |  |
|  | T | **T Turnover Engineering** |  |  | 2009-12-01 | 2010-10-05 |  |  |  |  |  |  |  |  |  |  |  |  |  |  |  |  |  |  |  |  |  |  |  |  |
| ET000100 |  | Definition of Turnover structure (Subsystem definition) |  | 73d | 2009-12-01 A | 2010-03-17 A | DE1000 | 100% | TME [4800 h] | 4800,00 | ET000100 | ET000100 | 934 | 0D |  | 200 | 200 | 002 | E | 3B | LND | 1 | E | T | 0000 | 0000 | 00 | LND |  |  |
| ET000110 |  | Preparation of Database/ Templates f. Turnover-documentation |  | 139d | 2010-03-19 A | 2010-10-05 A | ET000100, ETF00100 FF | 100% | TME [1920 h] | 1920,00 | ET000110 | ET000110 | 934 | 0D |  | 200 | 200 | 002 | E | 3B | LND | 1 | E | T | 0000 | 0000 | 00 | LND |  |  |
| ETB00100 |  | Prep. Equipment/ PU's Turnover documentation |  | 34d | 2010-05-03 A | 2010-06-21 A | DE1000 | 100% | TME [656 h] | 656,00 | ETB00100 | ETB00100 | 934 | 0D |  | 200 | 200 | 002 | E | 3B | LND | 1 | E | T | 0000 | 0000 | 00 | LND |  |  |
| ETM00100 |  | Prep. Painting Turnover documentation |  | 55d | 2010-05-03 A | 2010-07-20 A | DE1000 | 100% | TME [656 h] | 656,00 | ETM00100 | ETM00100 | 934 | 0D |  | 200 | 200 | 002 | E | 3B | LND | 1 | E | T | 0000 | 0000 | 00 | LND |  |  |
| ETR00100 |  | Prep. U/G piping Turnover documentation |  | 34d | 2010-05-03 A | 2010-06-21 A | DE1000 | 100% | TME [656 h] | 656,00 | ETR00100 | ETR00100 | 934 | 0D |  | 200 | 200 | 002 | E | 3B | LND | 1 | E | T | 0000 | 0000 | 00 | LND |  |  |
| ETR00110 |  | Prep. A/G piping Turnover documentation |  | 34d | 2010-05-03 A | 2010-06-21 A | DE1000 | 100% | TME [656 h] | 656,00 | ETR00110 | ETR00110 | 934 | 0D |  | 200 | 200 | 002 | E | 3B | LND | 1 | E | T | 0000 | 0000 | 00 | LND |  |  |
| ET000120 |  | Turnover procedure prep./ issuance |  | 67.5d | 2010-05-18 A | 2010-08-20 A | ET000110 FF+5d | 100% | TME [1280 h] | 1280,00 | ET000120 | ET000120 | 934 | 0D |  | 200 | 200 | 002 | E | 3B | LND | 1 | E | T | 0000 | 0000 | 00 | LND |  |  |
| ETM00110 |  | Prep. Insulation Turnover documentation |  | 40d | 2010-05-26 A | 2010-07-20 A | ETM00100 FF | 100% | TME [656 h] | 656,00 | ETM00110 | ETM00110 | 934 | 0D |  | 200 | 200 | 002 | E | 3B | LND | 1 | E | T | 0000 | 0000 | 00 | LND |  |  |
|  | 90 | **90 U/G Systems - CA90** |  |  | 2009-12-14 | 2011-02-28 |  |  |  |  |  |  |  |  |  |  |  |  |  |  |  |  |  |  |  |  |  |  |  |  |
|  | C | **C Civil** |  |  | 2009-12-14 | 2011-02-28 |  |  |  |  |  |  |  |  |  |  |  |  |  |  |  |  |  |  |  |  |  |  |  |  |
| EC0730 |  | General UG concrete drwgs - Check & Release of working drwgs (AFC) |  | 305d | 2009-12-14 A | 2011-02-28 A | EC303110 FF | 100% | TKB-B [1632 h] | 1632,00 | EC0730 | EC0730 | 87A | 0D |  | 200 |  |  | E |  | LND | FL | E | C | EC07 | 90 | cq | LND | 999 |  |
|  | 10 | **10 CA10 - Propylene Recovery Unit Area** |  |  | 2008-05-19 | 2011-12-07 |  |  |  |  |  |  |  |  |  |  |  |  |  |  |  |  |  |  |  |  |  |  |  |  |
|  | LUZ2 | **LUZ2 General ( )** |  |  | 2008-05-19 | 2009-12-16 |  |  |  |  |  |  |  |  |  |  |  |  |  |  |  |  |  |  |  |  |  |  |  |  |
|  | U | **U Package Units** |  |  | 2008-05-19 | 2009-12-16 |  |  |  |  |  |  |  |  |  |  |  |  |  |  |  |  |  |  |  |  |  |  |  |  |
| E3U1220 |  | PU12 Propyl.Recov.Unit - Techn. Eval./PO Spec. |  | 399d | 2008-05-19 A | 2009-12-16 A | P3U12C FF, HEB20 FF | 100% | TAA [800 h] | 800,00 | E3U1220 | E3U1220 | 869 | 10 | DC | 200 | 200 | 400 | E | 3A | LND | C2 | E | U | EU94 | LUZ2 | 2 | LND | 2KB4240 | PU12 |
| E3U1230 |  | PU12 Propyl.Recov.Unit - Techn. Eval./Bid Tab Fi | milestone | 0d | 2008-07-19 A | 2008-07-19 A | F8340, E3U1220 FF-5d | 100% |  |  | E3U1230 | E3U1230 | 869 | 10 |  | 200 | 200 | 055 | E |  | LND | C2 | E | U | EU94 | LUZ2 | 2 | LND | 2KB4240 | PU12 |
|  | 1010 | **1010 Propylene Recovery Unit Area - CA10** |  |  | 2009-06-02 | 2011-12-07 |  |  |  |  |  |  |  |  |  |  |  |  |  |  |  |  |  |  |  |  |  |  |  |  |
|  | L | **L Plant Design** |  |  | 2010-06-30 | 2010-06-30 |  |  |  |  |  |  |  |  |  |  |  |  |  |  |  |  |  |  |  |  |  |  |  |  |
| ER10000 |  | 30% Design Review CA10 - PRU Section |  | 1d | 2010-06-30 A | 2010-06-30 A | E3U1240 FS+20d | 100% |  |  | ER10000 | ER10000 | 876 | 10 |  | 200 |  | 050 | AD |  | LEI |  | E | L | ER33 | 1010 | 1 | LND |  |  |

| ID | WBS | Activity | Type | Duration | Start | Finish | Predecessors | Complete | Remaining | Total float | Free float | Resources | UDF_SAVE ACTID | UDF_SAVE ACT ID | Department | Constr. Area | Pro Unit/DocCode | PMT-Area | PMT-Phase | PMT-Respons. | Zeigen/n. Zeigen | WBS Phase | WBS Discipline | WBS Type of Work | WBS Objects | IMS | UPT | TB26 Ressource Budget | Inquiry/Order No | PMT-Schedule Org | Type of Work | PMT-Discipline |
| --- | --- | --- | --- | --- | --- | --- | --- | --- | --- | --- | --- | --- | --- | --- | --- | --- | --- | --- | --- | --- | --- | --- | --- | --- | --- | --- | --- | --- | --- | --- | --- | --- |
|  | C | **C Civil** |  |  | 2010-09-23 | 2011-09-09 |  |  |  |  |  |  |  |  |  |  |  |  |  |  |  |  |  |  |  |  |  |  |  |  |  |  |
| EC241010 |  | CA10 PRU Area - Foundation Data Sheets IFD |  | 15d | 2010-09-23 A | 2010-10-13 A | EB051010 FF, EN251010 | 100% |  |  |  |  | EC241010 | EC241010 | 87A | 10 | 1000C01 | 200 | E | LND | FL | E | C | EC24 | 1010 | de | LND |  |  |  |  |  |
| EC071005 |  | CA10 PRU Area - Issue of working drwgs (AFC) by RDI |  | 130d | 2010-10-14 A | 2011-04-18 A | EC45101010 FF, EC601000 FF, EC151010 SS | 100% |  |  |  | TKB-B [2000 h] | EC071005 | EC071005 | 87A | 10 | 1010C13 | 200 | E | IPR | FL | E | C | EC07 | 1010 | cq | LND | 2000,00 | 999 |  |  |  |
| EC151010 |  | CA10 PRU Area - Piling drwgs AFC |  | 36d | 2010-10-14 A | 2010-12-03 A | EC261010 SS, IMS-E-000130 FF | 100% |  |  |  |  | EC151010 | EC151010 | 87A | 10 | 1010C16 | 200 | E | IPR | FL | E | C | EC15 | 1010 | de | LND |  | 999 |  |  |  |
| EC261010 |  | CA10 PRU Area - Civil Static Calc EqptFdtn |  | 36d | 2010-10-14 A | 2010-12-03 A | EC241010 | 100% |  |  |  |  | EC261010 | EC261010 | 87A | 10 | 1010C14 | 200 | E | IPR | FL | E | C | EC26 | 1010 | de | LND |  | 999 |  |  |  |
| EC281010 |  | CA10 PRU Area - Formw/Reinforce drwgs AFC |  | 36d | 2010-10-14 A | 2010-12-03 A | EC151010 FF, EC261010 SS | 100% |  |  |  |  | EC281010 | EC281010 | 87A | 10 | 1010C21 | 200 | E | IPR | FL | E | C | EC28 | 1010 | de | LND |  |  | 200 |  |  |
| EC441010 |  | CA10 PRU Area - General Drwgs & Documents |  | 36d | 2010-10-14 A | 2010-12-03 A | EC45101005 FF | 100% |  |  |  |  | EC441010 | EC441010 | 87A | 10 | 1000C11 | 200 | E | IPR |  | E | C | EC00 | 1010 | de | LND |  |  |  |  |  |
| EC45101005 |  | CA10 PRU Area - Civil Layout drwgs AFC |  | 36d | 2010-10-14 A | 2010-12-03 A | EC241010, EC261010 SS | 100% |  |  |  |  | EC45101005 | EC45101005 | 87A | 10 | 1010C13 | 200 | E | IPR | FL | E | C | EC45 | 1010 | cq | LND |  | 999 |  |  |  |
| EC601000 |  | CA10 PRU Area - Paving drwgs AFC |  | 130d | 2010-10-14 A | 2011-04-18 A | EC120 FF, HEC60 FF, EC281010 FF, EC301000 SS+20d | 100% |  |  |  |  | EC601000 | EC601000 | 87A | 10 | 9610C96 | 200 | E | IPR |  | E | C | EC60 | 1010 | cq | LND |  |  | 200 |  |  |
| EC071010 |  | CA10 PRU Area - Check & Release of working drwgs (AFC) |  | 39d | 2010-11-04 A | 2010-12-30 A | EC45101005 SS+15d | 100% |  |  |  | TKB-B [320 h] | EC071010 | EC071010 | 87A | 10 | 1010C13 | 200 | E | LND | FL | E | C | EC07 | 1010 | cq | LND | 320,00 | 999 |  |  |  |
| EC45101010 |  | CA10 PRU Area - Civil Layout drwgs IFC | milestone | 0d | 2010-11-22 A | 2010-11-22 A | EC45101005 FF-8d | 100% |  |  |  |  | EC45101010 | EC45101010 | 87A | 10 |  | 200 | E | IPR | FL | E | C | EC45 | 1010 | cq | LND |  |  |  |  |  |
| EC241810 |  | CA18 Ciller Unit Area - Foundation Data Sheets/Layout Drwgs IFD |  | 10d | 2011-05-10 A | 2011-05-23 A | EB051810, E3M1810 FF, EN251801 FF+5d, E3A02D10 FF | 100% |  |  |  |  | EC241010 | EC241810 | 87A | 18 | 1000C01 | 200 | E | LND | FL | E | C | EC24 | 1810 | de | LND |  |  |  |  |  |
| EC151810 |  | CA18 Ciller Unit Area - Piling drwgs AFC |  | 25d | 2011-05-24 A | 2011-06-27 A | EC261810 SS, P3C0CE | 100% |  |  |  |  | EC151010 | EC151810 | 87A | 18 | 1010C16 | 200 | E | IPR | FL | E | C | EC15 | 1810 | de | LND |  | 999 |  |  |  |
| EC261810 |  | CA18 Ciller Unit Area - Civil Static Calc EqptFdtn |  | 25d | 2011-05-24 A | 2011-06-27 A | P3C0CE, EC241810 | 100% |  |  |  |  | EC261010 | EC261810 | 87A | 18 | 1010C14 | 200 | E | IPR | FL | E | C | EC26 | 1810 | de | LND |  | 999 |  |  |  |
| EC281810 |  | CA18 Ciller Unit Area - Formw/Reinforce drwgs AFC |  | 74d | 2011-05-31 A | 2011-09-09 | EC151810 FF, EC261810 SS+5d | 100% | 7d | 444.5d |  |  | EC281010 | EC281810 | 87A | 18 | 1010C21 | 200 | E | IPR | FL | E | C | EC28 | 1810 | de | LND |  |  | 200 |  |  |
|  | N | **N Structural Steel** |  |  | 2010-07-26 | 2011-12-07 |  |  |  |  |  |  |  |  |  |  |  |  |  |  |  |  |  |  |  |  |  |  |  |  |  |  |
| EN151010 |  | CA10 PRU SK1001 - CAD Model/Concepts StrSteel |  | 38d | 2010-07-26 A | 2010-09-15 A | ER10000 | 100% |  |  |  | TKB-S [480 h] | EN151010 | EN151010 | 87B | 10 |  | 200 | E | LEI | FL | E | N | EN15 | 1010 | de | LND | 480,00 | N02X | 200 | N02X | 055 |
| EN21101005 |  | CA10 PRU SK1001 - GA-Drwgs + Fdtn Loads |  | 15d | 2010-08-26 A | 2010-09-15 A | EN151010 FF, EE46101005, ER10000, ER161010, EJ46101005 | 100% |  |  |  | TKB-S [320 h] | EN21101005 | EN21101005 | 87B | 10 |  | 200 |  | LEI | FL | E | N | EN21 | 1010 | de | LND | 320,00 | N02X |  | N02X |  |
| EN24101005 |  | CA10 PRU SK1001 - StaticCalc f.Fdtn Load |  | 10d | 2010-09-09 A | 2010-09-22 A | EN21101005 FF+5d | 100% |  |  |  |  | EN24101005 | EN24101005 | 87B | 10 |  | 200 |  | LEI | FL | E | N | EN24 | 1010 | de | LND |  | N02X |  | N02X |  |
| EN251010 |  | CA10 PRU SK1001 - Loads for Civil | milestone | 0d | 2010-09-22 A | 2010-09-22 A | EN24101005 FF | 100% |  |  |  |  | EN251010 | EN251010 | 87B | 10 |  | 200 | E | LEI | FL | E | N | EN25 | 1010 | de | LND |  | N02X | 200 | N02X | 055 |
| EN21101010 |  | CA10 PRU SK1001 - GA-Drwgs + Final Loads |  | 15d | 2010-09-29 A | 2010-10-19 A | EN21101005 FS+5d, EE46101008, EJ46101008 FS+6d, EB051010, EN251010 | 100% |  |  |  | TKB-S [320 h] | EN21101010 | EN21101010 | 87B | 10 |  | 200 |  | LEI | FL | E | N | EN21 | 1010 | de | LND | 320,00 | N02X |  | N02X |  |
| EN24101010 |  | CA10 PRU SK1001 - Final Static Calc |  | 28d | 2010-10-20 A | 2010-11-29 A | EN21101010, ER191010 FF | 100% |  |  |  |  | EN24101010 | EN24101010 | 87B | 10 |  | 200 |  | LEI | FL | E | N | EN24 | 1010 | de | LND |  | N02X |  | N02X |  |
| EN261010 |  | CA10 PRU SK1001 - Layout dwgs input for KM dwgs |  | 33d | 2010-10-22 A | 2010-12-08 A | EN24101010 FF+7d | 100% |  |  |  | TKB-S [800 h] | EN261010 | EN261010 | 87B | 10 |  | 200 |  | LEI | FL | E | N | EN26 | 1010 | de | LND | 800,00 | N02X |  | N02X |  |
| EN671010 |  | CA10 PRU SK1001 - Grating Cut-Out drwgs |  | 79d | 2010-11-22 A | 2011-03-14 A | EN27101010 SS+5d, EN261010 FF+10d, F4465 FF+10d | 100% |  |  |  | TKB-S [240 h] | EN671010 | EN671010 | 87B | 10 |  | 200 | C | LEI | FL | E | N | EN67 | 1010 | de | LND | 240,00 | N02X | 200 | N02X |  |
| EN27101005 |  | CA10 PRU SK1001 - KM drwgs |  | 61d | 2010-12-16 A | 2011-03-14 A | EN261010, E3C170 FF, EN24101005 | 100% |  |  |  | KM Drwgs preparation by Cheljabinsk [23 t] | EN27101005 | EN27101005 | 87B | 10 |  | 200 |  | Chel | FL | E | N | EN27 | 1010 | st | LND | 0,00 | N02X |  | N02X |  |
| EN27101010 |  | CA10 PRU SK1001 - Check KM drwgs |  | 10d | 2011-03-14 A | 2011-03-25 A | EN27101005 FF+9d | 100% |  |  |  |  | EN27101010 | EN27101010 | 87B | 10 |  | 200 |  | LEI | FL | E | N | EN27 | 1010 | st | LND |  | N02X |  | N02X |  |
| EN281010 |  | CA10 PRU SK1001 - Shop dwgs(KMD) by Vendor |  | 25d | 2011-03-14 A | 2011-04-15 A | IMS-E-000180 FF, EN27101010 FF+15d | 100% |  |  |  |  | EN281010 | EN281010 | 87B | 10 |  | 200 |  | Chel | FL | E | N | EN28 | 1010 | de | LND |  | N02X |  | N02X |  |
| EN681010 |  | CA10 PRU SK1001 - Grating Fabrication drwgs |  | 25d | 2011-03-15 A | 2011-04-18 A | EN671010 | 100% |  |  |  |  | EN681010 | EN681010 | 87B | 10 |  | 200 | C | SC | FL | E | N | EN68 | 1010 | de | LND |  | N02X | 200 | N02X |  |
| EN151801 |  | CA18 Chiller Unit SK1801 - CAD Model/Concepts StrSteel |  | 15d | 2011-04-12 A | 2011-05-02 A | P030010 | 100% |  |  |  |  | EN151010 | EN151801 | 87B | 18 |  | 200 | E | LEI | FL | E | N | EN15 | 1810 | de | LND |  | N02~ | 200 | N02~ | 055 |
| EN651010 |  | CA10 PRU SK1001 - Check Grating Fabrication drwgs |  | 2d | 2011-04-19 A | 2011-04-20 A | EN681010 | 100% |  |  |  |  | EN651010 | EN651010 | 87B | 10 |  | 200 | C | LEI | FL | E | N | EN65 | 1010 | de | LND |  | N02X | 200 | N02X |  |
| EN21180105 |  | CA18 Chiller Unit SK1801 - GA-Drwgs + Fdtn Loads |  | 10d | 2011-05-03 A | 2011-05-16 A | EN151801 | 100% |  |  |  |  | EN21101005 | EN21180105 | 87B | 18 |  | 200 |  | LEI | FL | E | N | EN21 | 1810 | de | LND |  | N02~ |  | N02~ |  |
| EN24180105 |  | CA18 Chiller Unit SK1801 - StaticCalc f.Fdtn Load |  | 10d | 2011-05-03 A | 2011-05-16 A | EN21180105 FF | 100% |  |  |  |  | EN24101005 | EN24180105 | 87B | 18 |  | 200 |  | LEI | FL | E | N | EN24 | 1810 | de | LND |  | N02~ |  | N02~ |  |
| EN251801 |  | CA18 Chiller Unit SK1801 - Loads for Civil | milestone | 0d | 2011-05-16 A | 2011-05-16 A | EN24180105 FF | 100% |  |  |  |  | EN251010 | EN251801 | 87B | 18 |  | 200 | E | LEI | FL | E | N | EN25 | 1810 | de | LND |  | N02~ | 200 | N02~ | 055 |
| EN21180110 |  | CA18 Chiller Unit SK1801 - GA-Drwgs + Final Loads |  | 15d | 2011-05-24 A | 2011-06-13 A | EN21180105 FS+5d, EN251801 | 100% |  |  |  |  | EN21101010 | EN21180110 | 87B | 18 |  | 200 |  | LEI | FL | E | N | EN21 | 1810 | de | LND |  | N02~ |  | N02~ |  |
| EN24180110 |  | CA18 Chiller Unit SK1801 - Final Static Calc |  | 59d | 2011-06-14 A | 2011-09-02 | EN21180110, EE46181010 FF |  | 2d | 353d | 0d |  | EN24101010 | EN24180110 | 87B | 18 |  | 200 |  | LEI | FL | E | N | EN24 | 1810 | de | LND |  | N02~ |  | N02~ |  |
| EN261801 |  | CA18 Chiller Unit SK1801 - Layout dwgs input for KM dwgs |  | 59d | 2011-06-23 A | 2011-09-13 | EN24180110 FF+7d |  | 9d | 353d | 0d |  | EN261010 | EN261801 | 87B | 18 |  | 200 |  | LEI | FL | E | N | EN26 | 1810 | de | LND |  | N02~ |  | N02~ |  |
| EN27180105 |  | CA18 Chiller Unit SK1801 - KM drwgs |  | 25d | 2011-09-14 | 2011-10-19 | EN261801, EN24180105 |  |  | 353d | 0d |  | EN27101005 | EN27180105 | 87B | 18 |  | 200 |  | Chel | FL | E | N | EN27 | 1810 | st | LND |  | N02~ |  | N02~ |  |
| EN27180110 |  | CA18 Chiller Unit SK1801 - Check KM drwgs |  | 10d | 2011-10-19 | 2011-11-02 | EN27180105 FF+9d |  |  | 353d | 0d |  | EN27101010 | EN27180110 | 87B | 18 |  | 200 |  | LEI | FL | E | N | EN27 | 1810 | st | LND |  | N02~ |  | N02~ |  |
| EN281801 |  | CA18 Chiller Unit SK1801 - Shop dwgs(KMD) by Vendor |  | 25d | 2011-11-03 | 2011-12-07 | EN27180110 |  |  | 353d | 0d |  | EN281010 | EN281801 | 87B | 18 |  | 200 |  | Chel | FL | E | N | EN28 | 1810 | de | LND |  | N02~ |  | N02~ |  |

Notes:
- EC441010: P3 Activity Log Info: incl. PMT / approval
- EC45101010: P3 Activity Log Info: incl. PMT / approval

| ID | WBS | Activity | Type | Duration | Start | Finish | Predecessors | Complete | Total float | Constraint | Resources | UDF_SAVE ACTID | UDF_SAVE ACT ID | Department | Constr. Area | PMT-Area | PMT-Respons. | Zeigen/n. Zeigen | WBS Phase | WBS Discipline | WBS Type of Work | WBS Objects | IMS | UPT | PMT-Schedule Org | PMT-Phase | TB26 Ressource Budget | Pro Unit/DocCode |
| --- | --- | --- | --- | --- | --- | --- | --- | --- | --- | --- | --- | --- | --- | --- | --- | --- | --- | --- | --- | --- | --- | --- | --- | --- | --- | --- | --- | --- |
|  | B | **B Mechanical - Stationary Equipment** |  |  | 2010-09-28 | 2011-04-29 |  |  |  |  |  |  |  |  |  |  |  |  |  |  |  |  |  |  |  |  |  |  |
| EB051010 |  | CA10 PRU Area - Final Loads for Struc Steel | milestone | 0d | 2010-09-28 A | 2010-09-28 A | ER10000 | 100% |  |  |  | EB051010 | EB051010 | 869 | 10 | 200 | LND | FL | E | B | EB05 | 1010 | 3 | LND |  |  |  |  |
| EB051810 |  | CA18 Chiller Unit Area - Loads for Civil | milestone | 0d | 2011-04-29 A | 2011-04-29 A | E3M1720 FF-20d | 100% |  |  |  | EB051010 | EB051810 | 867 | 18 | 200 | LND |  | E | M | EM05 | 1810 | 3 | LND |  |  |  |  |
|  | R | **R Piping** |  |  | 2009-06-02 | 2010-12-22 |  |  |  |  |  |  |  |  |  |  |  |  |  |  |  |  |  |  |  |  |  |  |
| ER151010 |  | CA10 PRU Section - Conceptual Piping |  | 242d | 2009-06-02 A | 2010-05-17 A | F2760 | 100% |  |  |  | ER151010 | ER151010 | 876 | 10 | 200 | LND | FL | E | R | ER15 | 1010 | 1 | LND |  |  |  |  |
| ER301010 |  | CA10 PRU Section - CAD Model Piping / Eqpt |  | 258d | 2009-10-29 A | 2010-11-05 A | ER151010 SS, ER391010 FF+5d | 100% |  |  |  | ER301010 | ER301010 | 876 | 10 | 200 | LNI | FL | E | R | ER30 | 1010 | 1 | LND |  |  |  |  |
| ER161010 |  | CA10 PRU Section - prelim Loads for SteelStruc |  | 15d | 2010-04-26 A | 2010-05-17 A | ER151010 FF | 100% |  |  |  | ER161010 | ER161010 | 876 | 10 | 200 | LND | FL | E | R | ER16 | 1010 | de | LND |  |  |  |  |
| ER361010 |  | CA10 PRU - CAD Model Review 60% |  | 2d | 2010-09-20 A | 2010-09-21 A | F4048 FF | 100% |  |  |  | ER361010 | ER361010 | 876 | 10 | 200 | LND | FL | E | R | ER36 | 1010 | 2 | LND |  |  |  |  |
| ER391010 |  | CA10 PRU - CAD Model Review 90% |  | 2d | 2010-09-20 A | 2010-09-21 A | F4465 FF | 100% |  |  |  | ER391010 | ER391010 | 876 | 10 | 200 | LND | FL | E | R | ER39 | 1010 | 3 | LND |  |  |  |  |
| ER421010 |  | CA10 PRU - Stress Calculation |  | 30d | 2010-10-06 A | 2010-11-16 A | ER361010 FF | 100% |  |  |  | ER421010 | ER421010 | 872 | 10 | 200 | LND | FL | E | R | ER42 | 1010 | 1 | LND |  |  |  |  |
| ER441010 |  | CA10 PRU - Piping Isometrics (UG) |  | 20d | 2010-10-11 A | 2010-11-05 A | EC301000 SS+20d, ER440000 FF, IMS-E-000100 FF, HER44 FF | 100% |  |  |  | ER441010 | ER441010 | 876 | 10 | 200 | LND |  | E | R | ER44 | 1010 | 4 | LND | 200 | E |  |  |
| ER451010 |  | CA10 PRU - Piping Isometrics |  | 20d | 2010-11-18 A | 2010-12-15 A | ER301010 FF, ER391010, ER421010 | 100% |  |  |  | ER451010 | ER451010 | 876 | 10 | 200 | LEI | FL | E | R | ER45 | 1010 | 5 | LND |  |  |  |  |
| ER491010 |  | CA10 PRU - Design Check / Rel.Isos&BOM |  | 25d | 2010-11-18 A | 2010-12-22 A | ER451010 SS, IMS-E-000110 FF | 100% |  | finish on 2010-12-22 |  | ER491010 | ER491010 | 876 | 10 | 200 | LEI | FL | E | R | ER49 | 1010 | 5 | LND |  |  |  |  |
| ER191010 |  | CA10 PRU - Final Loads for SteelStruc | milestone | 0d | 2010-11-30 A | 2010-11-30 A | F4048 FF, EN21141010 SF-15d, EN21101010 SF-10d, ER161010 FF | 100% |  |  |  | ER191010 | ER191010 | 876 | 10 | 200 | LNI | FL | E | R | ER19 | 1010 | de | LND |  |  |  |  |
|  | E | **E Electrical** |  |  | 2009-06-22 | 2011-01-18 |  |  |  |  |  |  |  |  |  |  |  |  |  |  |  |  |  |  |  |  |  |  |
| EE901010 |  | CA10 PC VentComprArea - Earthing Details |  | 30d | 2009-06-22 A | 2009-07-31 A | EE901410 FF | 100% |  |  |  | EE901010 | EE901010 | 874 | 10 |  | LND | FL | E | E | EE90 | 1010 | E | LND |  | E |  |  |
| EE900010 |  | General - Earthing Details finalized |  | 76d | 2009-11-23 A | 2010-03-12 A | EE901610, EE905101, EE905102, EE901710, EE901410 FS+95d | 100% |  |  | TAE [1600 h] | EE900010 | EE900010 | 874 | 10 |  | LND | FL | E | E | EE90 | 1010 | E | LND |  | E | 1600,00 |  |
| EE761010 |  | CA10 PRU Area - Layout Plan Light.&Sockets 1st Issue |  | 249d | 2010-01-26 A | 2011-01-18 A | EE000180 | 100% |  |  |  | EE761010 | EE761010 | 874 | 10 |  | LEI | FL | E | E | EE76 | 1010 | E | LND |  | E |  |  |
| EE46101005 |  | CA10 PRU - prelimLoads f.Struc Steel |  | 53d | 2010-03-25 A | 2010-06-11 A | ER10000 FF | 100% |  |  |  | EE46101005 | EE46101005 | 874 | 10 |  | LND | FL | E | E | EE11 | 1010 | E | LND |  | E |  |  |
| EE46101008 |  | CA10 PRU - Final Loads f.Struc Steel |  | 20d | 2010-09-01 A | 2010-09-28 A | EE46101005 | 100% |  |  |  | EE46101008 | EE46101008 | 874 | 10 |  | LEI | FL | E | E | EE12 | 1010 | E | LND |  | E |  |  |
|  | J | **J Instrumentation** |  |  | 2009-12-21 | 2011-11-03 |  |  |  |  |  |  |  |  |  |  |  |  |  |  |  |  |  |  |  |  |  |  |
| EJ46101005 |  | CA10 PRU - prelim Loads f.Struc Steel |  | 117d | 2009-12-21 A | 2010-06-11 A | F3060 | 100% |  |  |  | EJ46101005 | EJ46101005 | 86E | 10 |  | LND | FL | E | J | EJ11 | 1010 | I | LND |  | E |  | 999 |
| EJ361010 |  | CA10 PRU Section - Hook-Up drwgs |  | 67d | 2010-07-28 A | 2010-10-28 A | EJ360000 FF, F4048 FF+10d | 100% |  |  |  | EJ361010 | EJ361010 | 86E | 10 | 200 | LEI | FL | E | J | EJ36 | 1010 | I | LND | 200 | C |  | 999 |
| EJ801010 |  | CA10 PRU - Loop Diagrams |  | 70d | 2010-08-20 A | 2010-11-26 A | EJ800010, A1EJ0040 SF | 100% |  |  |  | EJ801010 | EJ801010 | 86E | 10 |  | LEI | FL | E | J | EJ80 | 1010 | I | LND |  | E |  | 999 |
| EJ321010 |  | CA10 PRU - JB Location drwgs |  | 57d | 2010-09-01 A | 2010-11-19 A | F4465 FF+10d | 100% |  |  |  | EJ321010 | EJ321010 | 86E | 10 | 200 | LEI | FL | E | J | EJ37 | 1010 | I | LND | 200 | C |  | 999 |
| EJ46101008 |  | CA10 PRU - Final Loads f.Struc Steel |  | 10d | 2010-09-07 A | 2010-09-20 A | EJ46101005 | 100% |  |  |  | EJ46101008 | EJ46101008 | 86E | 10 |  | LEI | FL | E | J | EJ12 | 1010 | I | LND |  | E |  | 999 |
| EJ801810 |  | CA18 Chiller Unit - Loop Diagrams |  | 30d | 2011-09-21 | 2011-11-03 | EJ000300 |  | 407.5d |  |  | EJ801010 | EJ801810 | 86E | 18 |  | LEI | FL | E | J | EJ80 | 1810 | I | LND |  | E |  | 999 |

| ID | WBS | Activity | Type | Duration | Start | Finish | Predecessors | Complete | Resources | Cost | Actual cost | UDF_SAVE ACTID | UDF_SAVE ACT ID | Department | Type of Work | Constr. Area | Pro Unit/DocCode | Inquiry/Order No | PMT-Area | PMT-Schedule Org | PMT-Discipline | PMT-Phase | PMT-Stage | PMT-Respons. | Zeigen/n. Zeigen | WBS Phase | WBS Discipline | WBS Type of Work | WBS Objects | IMS | UPT | PMT-Doc. Type | TB26 Ressource Budget |
| --- | --- | --- | --- | --- | --- | --- | --- | --- | --- | --- | --- | --- | --- | --- | --- | --- | --- | --- | --- | --- | --- | --- | --- | --- | --- | --- | --- | --- | --- | --- | --- | --- | --- |
|  | 11 | **11 CA11 - Offgas Compression Line 1 + 2** |  |  | 2008-03-03 | 2011-05-16 |  |  |  |  |  |  |  |  |  |  |  |  |  |  |  |  |  |  |  |  |  |  |  |  |  |  |  |
|  | LUZ2 | **LUZ2 General ( )** |  |  | 2008-04-22 | 2010-07-30 |  |  |  |  |  |  |  |  |  |  |  |  |  |  |  |  |  |  |  |  |  |  |  |  |  |  |  |
|  | B | **B Mechanical - Stationary Equipment** |  |  | 2008-04-22 | 2010-07-30 |  |  |  |  |  |  |  |  |  |  |  |  |  |  |  |  |  |  |  |  |  |  |  |  |  |  |  |
| E3A1620 |  | A16 Offgas C Filters - Techn. Eval./PO Spec |  | 42d | 2008-04-22 A | 2008-06-20 A | F5810, P3A16C FF | 100% |  |  |  | E3A1620 | E3A1620 | 869 | A16 | 11 | DC | 2DC8560 | 200 | 200 | 400 | E | 3A | LND | C2 | E | B | EB84 | LUZ2 | 3 | LND |  |  |
| E3A1630 |  | A16 Offgas C Filters -Techn. Eval./Bid Tab F | milestone | 0d | 2008-05-31 A | 2008-05-31 A | E3A1620 FF-6d, F5890 | 100% |  |  |  | E3A1630 | E3A1630 | 869 | A16 | 11 |  | 2DC8560 | 200 | 200 | 055 | E |  | LND | C2 | E | B | EB84 | LUZ2 | 3 | LND |  |  |
| E3A1640 |  | A16 Offgas C Filters - 1st Review Vendor Dwgs |  | 9d | 2008-09-08 A | 2008-09-18 A | P3A16D1 FS+48d | 100% |  |  |  | E3A1640 | E3A1640 | 869 | A16 | 11 | DC | 2DC8560 | 200 | 200 | 400 | E | 3A | LND | C2 | E | B | EB85 | LUZ2 | 3 | LND | DFA |  |
| E3A1650 |  | A16 Offgas C Filters - Vendor dwgs approved | milestone | 0d | 2008-09-19 A | 2008-09-19 A | E3A1640 FF | 100% |  | 76,400 | 76,400 | E3A1650 | E3A1650 | 869 | A16 | 11 | DC | 2DC8560 | 200 | 200 | 400 | E |  | LND | C2 | E | B | EB85 | LUZ2 | 3 | LND |  |  |
| E3A1660 |  | A16 Offgas C Filters - Final Review Vendor Dwgs |  | 44d | 2010-06-01 A | 2010-07-30 A | P3A16D1 FS+60d, E3A1650 | 100% |  |  |  | E3A1660 | E3A1660 | 869 | A16 | 11 | DC | 2DC8560 | 200 | 200 | 400 | E |  | LND | C2 | E | B | EB85 | LUZ2 | 3 | LND |  |  |
|  | 0000 | **0000 Generals - all CA's** |  |  | 2008-07-14 | 2010-12-09 |  |  |  |  |  |  |  |  |  |  |  |  |  |  |  |  |  |  |  |  |  |  |  |  |  |  |  |
|  | C | **C Civil** |  |  | 2008-07-14 | 2010-12-09 |  |  |  |  |  |  |  |  |  |  |  |  |  |  |  |  |  |  |  |  |  |  |  |  |  |  |  |
| EC440000 |  | CA00 General - Civil Layout drwgs / Loads IFD | level of effort | 606d | 2008-07-14 A | 2010-12-09 A | EC221204 SS, EC221205 SS, EC441221 SS, EC241511 SS, EC221201 SS, EC441710 SS, EC443140 SS, EC225101 SS, EC441222 SS, EC441610 SS, EC443120 SS, EC443130 SS, EC241111 SS, EC241130 SS, EC241510 SS, EC443110 SS | 100% |  |  |  | EC440000 | EC440000 | 87A |  | 11 |  |  | 200 |  |  | E |  | LND |  | E | C | EC44 | 0000 | de | LND |  |  |
|  | 1100 | **1100 Generals CA11** |  |  | 2009-08-31 | 2011-04-22 |  |  |  |  |  |  |  |  |  |  |  |  |  |  |  |  |  |  |  |  |  |  |  |  |  |  |  |
|  | C | **C Civil** |  |  | 2009-08-31 | 2011-04-22 |  |  |  |  |  |  |  |  |  |  |  |  |  |  |  |  |  |  |  |  |  |  |  |  |  |  |  |
| EC441100 |  | CA11 General - Civil Layout drwgs / Loads IFD | level of effort | 55d | 2009-08-31 A | 2009-11-13 A | EC241111 FF, EC241111 SS | 100% |  |  |  | EC441100 | EC441100 | 87A |  | 11 | 1100C01 |  | 200 |  |  | E |  | LND |  | E | C | EC44 | 1100 | de | LND |  |  |
| EC071105 |  | CA11 General - Issue of working drwgs (AFC) by RDI |  | 339d | 2009-12-15 A | 2011-04-18 A | EC45111010 FF, EC45111110 FF, EC45111005 SS, EC601100 FF, EC701110 FF | 100% | TKB-B [12640 h] |  |  | EC071105 | EC071105 | 87A |  | 11 | 1010C13 | 999 | 200 |  |  | E |  | IPR | FL | E | C | EC07 | 1100 | cq | LND |  | 12640,00 |
| EC071100 |  | CA11 General - Check & Release of working drwgs (AFC) |  | 328d | 2010-01-11 A | 2011-04-22 A | EC601100 FF+4d, EC45111005 SS+35d | 100% | TKB-B [2368 h] |  |  | EC071100 | EC071100 | 87A |  | 11 |  | 999 | 200 |  |  | E |  | LND | FL | E | C | EC07 | 1100 | cq | LND |  | 2368,00 |
| EC44110005 |  | CA11 General - General Drwgs & Documents |  | 183d | 2010-02-08 A | 2010-10-26 A | EC45111005 FF | 100% |  |  |  | EC44110005 | EC44110005 | 87A |  | 11 | 1100C11 |  | 200 |  |  | E |  | IPR |  | E | C | EC00 | 1100 | de | LND |  |  |
| EC601100 |  | CA11 General - Paving drwgs AFC |  | 173d | 2010-08-16 A | 2011-04-18 A | EC301100 SS+10d, EC44110005 SS+30d, HEC60 FF, EC501110 FF | 100% |  |  |  | EC601100 | EC601100 | 87A |  | 11 | 9611C96 |  | 200 | 200 |  | E |  | IPR |  | E | C | EC60 | 1100 | de | LND |  |  |
|  | R | **R Piping** |  |  | 2010-10-11 | 2010-11-05 |  |  |  |  |  |  |  |  |  |  |  |  |  |  |  |  |  |  |  |  |  |  |  |  |  |  |  |
| ER441100 |  | CA11 General - Piping Isometrics (UG) |  | 20d | 2010-10-11 A | 2010-11-05 A | EC301100 SS+10d, ER440000 FF, HER44 FF | 100% |  |  |  | ER441100 | ER441100 | 876 |  | 11 |  |  | 200 | 200 |  | E |  | LND |  | E | R | ER44 | 1100 | 4 | LND |  |  |
|  | 1104 | **1104 Structures inside Offgas Compr Bldg - CA11** |  |  | 2008-03-03 | 2011-01-28 |  |  |  |  |  |  |  |  |  |  |  |  |  |  |  |  |  |  |  |  |  |  |  |  |  |  |  |
|  | N | **N Structural Steel** |  |  | 2008-03-03 | 2011-01-28 |  |  |  |  |  |  |  |  |  |  |  |  |  |  |  |  |  |  |  |  |  |  |  |  |  |  |  |
| EN151110 |  | CA11 Str.i.ComprBldg SK1105 - CAD Model/Concepts StrSteel |  | 126d | 2008-03-03 A | 2008-08-29 A | AD2230 FF | 100% |  |  |  | EN151110 | EN151110 | 87B | N02A | 11 |  | N02A | 200 | 200 | 055 | E |  | LND | 0 | E | N | EN15 | 1104 | de | LND |  |  |
| EN21111010 |  | CA11 Str.i.ComprBldg SK1105 - GA-Drwgs + Final Loads |  | 127d | 2009-12-21 A | 2010-06-25 A | EB051110, EM051110, HEN21 FF, EJ46111008 FF, EE46111008 FF+21d | 100% | TKB-S [720 h] |  |  | EN21111010 | EN21111010 | 87B | N02A | 11 |  | N02A | 200 |  |  |  |  | LEI |  | E | N | EN21 | 1104 | de | LND |  | 720,00 |
| EN24111010 |  | CA11 Str.i.ComprBldg SK1105 - Final Static Calc |  | 148d | 2009-12-28 A | 2010-07-29 A | ER191110 FF, EN21111010 SS | 100% | TKB-S [640 h] |  |  | EN24111010 | EN24111010 | 87B | N02A | 11 |  | N02A | 200 |  |  |  |  | LEI |  | E | N | EN24 | 1104 | de | LND |  | 640,00 |
| EN261110 |  | CA11 Str.i.ComprBldg SK1105 - Layout dwgs input for KM dwgs |  | 47d | 2010-05-26 A | 2010-07-29 A | EN24111010 FF, HEN26 FF, F4030 FF+20d | 100% | TKB-S [1120 h] |  |  | EN261110 | EN261110 | 87B | N02A | 11 |  | N02A | 200 |  |  |  |  | LEI |  | E | N | EN26 | 1104 | st | LND |  | 1120,00 |
| EN671110 |  | CA11 Str.i.ComprBldg SK1105 - Grating Cut-Out drwgs |  | 123d | 2010-05-26 A | 2010-11-12 A | F4460 FF+10d, ER421110 FF, EN261110 FF+10d | 100% | TKB-S [480 h] |  |  | EN671110 | EN671110 | 87B | N02A | 11 |  | N02A | 200 | 200 |  | C |  | LEI |  | E | N | EN67 | 1104 | de | LND |  | 480,00 |
| EN27111005 |  | CA11 Str.i.ComprBldg SK1105 - KM drwgs |  | 45d | 2010-07-30 A | 2010-09-30 A | EN261110, EC701110 SS+10d | 100% | KM Drwgs preparation by Cheljabinsk [31 t] |  |  | EN27111005 | EN27111005 | 87B | N02A | 11 |  | N02A | 200 |  |  |  |  | Chel |  | E | N | EN27 | 1104 | de | LND |  | 0,00 |
| EN27111010 |  | CA11 Str.i.ComprBldg SK1105 - Check KM drwgs |  | 20d | 2010-10-04 A | 2010-10-29 A | EN27111005 | 100% |  |  |  | EN27111010 | EN27111010 | 87B | N02A | 11 |  | N02A | 200 |  |  |  |  | LEI |  | E | N | EN27 | 1104 | de | LND |  |  |
| EN641110 |  | CA11 Str.i.ComprBldg SK1105 - Check Grating Cut-Out drwgs |  | 10d | 2010-11-03 A | 2010-11-16 A | EN671110 | 100% |  |  |  | EN641110 | EN641110 | 87B | N02A | 11 |  | N02A | 200 | 200 |  | C |  | LEI |  | E | N | EN67 | 1104 | de | LND |  |  |
| EN281110 |  | CA11 Str.i.ComprBldg SK1105 - Shop dwgs(KMD) by Vendor |  | 45d | 2010-11-23 A | 2011-01-26 A | HEN28 FF, EN27111010 FS+15d | 100% |  |  |  | EN281110 | EN281110 | 87B | N02A | 11 |  | N02A | 200 |  |  |  |  | Chel |  | E | N | EN28 | 1104 | de | LND |  |  |
| EN681110 |  | CA11 Str.i.ComprBldg SK1105 - Grating Fabrication drwgs |  | 45d | 2010-11-25 A | 2011-01-28 A | HEN68 FF, EN671110, EN641110 FS+5d | 100% |  |  |  | EN681110 | EN681110 | 87B | N02A | 11 |  | N02A | 200 | 200 |  | C |  | SC |  | E | N | EN68 | 1104 | de | LND |  |  |

Notes:
- E3A1650: Expenses: 900A 76400
- EC440000: P3 Activity Log Info: incl. PMT approval
- EC441100: P3 Activity Log Info: incl. PMT approval
- EC44110005: P3 Activity Log Info: incl. PMT approval

| ID | WBS | Activity | Type | Duration | Start | Finish | Predecessors | Complete | UDF_SAVE ACTID | UDF_SAVE ACT ID | Department | Constr. Area | PMT-Area | PMT-Phase | WBS Phase | WBS Discipline | WBS Type of Work | WBS Objects | IMS | UPT | PMT-Respons. | Pro Unit/DocCode | Zeigen/n. Zeigen | Type of Work | Inquiry/Order No | PMT-Schedule Org |
| --- | --- | --- | --- | --- | --- | --- | --- | --- | --- | --- | --- | --- | --- | --- | --- | --- | --- | --- | --- | --- | --- | --- | --- | --- | --- | --- |
|  | 1110 | **1110 Offgas Compressor Building - CA11** |  |  | 2008-03-03 | 2011-05-16 |  |  |  |  |  |  |  |  |  |  |  |  |  |  |  |  |  |  |  |  |
|  | 0B | **0B General Activities** |  |  | 2009-01-03 | 2009-01-03 |  |  |  |  |  |  |  |  |  |  |  |  |  |  |  |  |  |  |  |  |
| E0201110 |  | CA11 ComprBldg - freeze construction concept | milestone | 0d | 2009-01-03 A | 2009-01-03 A | F3600 | 100% | E0201110 | E0201110 | 87A | 11 | 200 | E | E | 0B | E020 | 1110 | INS | LND |  |  |  |  |  |  |
|  | C | **C Civil** |  |  | 2008-03-03 | 2011-04-04 |  |  |  |  |  |  |  |  |  |  |  |  |  |  |  |  |  |  |  |  |
| EC421110 |  | CA11 C.Bldg - Building Concept |  | 171d | 2008-03-03 A | 2008-11-04 A | F2760 | 100% | EC421110 | EC421110 | 87A | 11 | 200 | E | E | C | EC42 | 1110 | cq | LND | LND |  |  |  |  |  |
| EC241110 |  | CA11 C.Bldg - Fdtn Data Sheets ComprFdtn IFD |  | 116.12d | 2009-02-23 A | 2009-08-11 A | ER161110, EM051110, E3M0360, EB051110 | 100% | EC241110 | EC241110 | 87A | 11 | 200 | E | E | C | EC24 | 1110 | de | LND | LND | 1110C01 |  |  |  |  |
| EC26111005 |  | CA11 C.Bldg - Predimensioning ComprFdtn |  | 69d | 2009-08-17 A | 2009-11-20 A | EC241110 | 100% | EC26111005 | EC26111005 | 87A | 11 | 200 | E | E | C | EC26 | 1110 | de | LND | LND |  | C1 |  |  |  |
| EC441110 |  | CA11 C.Bldg - Building Layout drwgs IFD |  | 25d | 2009-08-31 A | 2009-10-02 A | EC440000 FF, EC441100 FF, EC221110 FF, EC241110 FF, E0201110, AD2230 FF+20d, EC421110, EC441100 SS | 100% | EC441110 | EC441110 | 87A | 11 | 200 | E | E | C | EC44 | 1110 | de | LND | LND | 1101C01 |  |  |  |  |
| EC221110 |  | CA11 C.Bldg - Civil Foundation Loads |  | 15d | 2009-09-15 A | 2009-10-05 A | EM051110, EB051110 | 100% | EC221110 | EC221110 | 87A | 11 | 200 |  | E | C | EC22 | 1110 | PI | LND | LND |  |  |  |  |  |
| EC131110 |  | CA11 C.Bldg - Fire Safety Survey Report |  | 313d | 2009-12-15 A | 2011-03-11 A | EC461110 SS | 100% | EC131110 | EC131110 | 87A | 11 | 200 | E | E | C | EC13 | 1110 | de | LND | IPR | 1101C15 |  |  |  |  |
| EC45111005 |  | CA11 C.Bldg - Building Layout drwgs AFC |  | 196d | 2009-12-15 A | 2010-09-24 A | EC461110 SS, P3C0BD, IMS-E-000170 FF, EH241110 FF, EC131110 SS, HEC45B FF, E3C110 FF, EC48100, AD2230, EC441110 | 100% | EC45111005 | EC45111005 | 87A | 11 | 200 | E | E | C | EC45 | 1110 | ar | LND | IPR | 1101C13 |  |  |  |  |
| EC461110 |  | CA11 C.Bldg - Civil Static Calc Bldg |  | 198d | 2009-12-15 A | 2010-09-28 A | EH051110 FF, EL10020 FF, P3C0BD, EC441110, EC463130 SS | 100% | EC461110 | EC461110 | 87A | 11 | 200 | E | E | C | EC46 | 1110 | de | LND | IPR | 1101C14 |  |  |  |  |
| EC151110 |  | CA11 C.Bldg - Piling drwgs AFC |  | 60d | 2010-01-11 A | 2010-04-06 A | EC261110 SS, HEC15 FF, EC131110 SS+10d, EC461110 SS+15d | 100% | EC151110 | EC151110 | 87A | 11 | 200 | E | E | C | EC15 | 1110 | PI | LND | IPR | 1101C16 |  |  |  |  |
| EC261110 |  | CA11 C.Bldg - Civil Static Calc ComprFdtn |  | 135d | 2010-01-18 A | 2010-07-29 A | EC26111005, EC461110 SS+20d, EC241110, P3C0BD FS+5d | 100% | EC261110 | EC261110 | 87A | 11 | 200 | E | E | C | EC26 | 1110 | de | LND | IPR | 1110C14 |  |  |  |  |
| EC48111003 |  | CA11 C.Bldg - Formw/Reinf drwgs Bldg Foundation AFC |  | 112d | 2010-01-25 A | 2010-07-05 A | EC151110 SS+10d, EC461110 SS+25d, HEC48B FF | 100% | EC48111003 | EC48111003 | 87A | 11 | 200 | E | E | C | EC48 | 1110 | ar | LND | IPR | 1101C21 |  |  |  |  |
| EC48111009 |  | CA11 C.Bldg - Precast/Formw/Reinf drwgs above Ground Level AFC |  | 185d | 2010-01-25 A | 2010-10-14 A | HEC48P FF, EC461110 SS+25d | 100% | EC48111009 | EC48111009 | 87A | 11 | 200 | E | E | C | EC48 | 1110 | ar | LND | IPR | 1101C53 |  |  |  |  |
| EC48111004 |  | CA11 C.Bldg - Precast drwgs Bldg AFC |  | 175d | 2010-02-08 A | 2010-10-14 A | EC48111003 SS+10d, HEC48P FF, EC461110 SS+25d | 100% | EC48111004 | EC48111004 | 87A | 11 | 200 | E | E | C | EC48 | 1110 | PRE | LND | IPR | 1101C31 |  |  |  |  |
| EC28111010 |  | CA11 C.Bldg - Formw/Reinf drwgs ComprFdtn AFC |  | 115d | 2010-02-15 A | 2010-07-29 A | EC261110 SS+20d, HEC28 FF | 100% | EC28111010 | EC28111010 | 87A | 11 | 200 | E | E | C | EC28 | 1110 | cq | LND | IPR | 1110C21 |  |  |  |  |
| EC48111005 |  | CA11 C.Bldg - Formw/Reinf drwgs Bldg GF +0,00m AFC |  | 119d | 2010-02-15 A | 2010-08-04 A | EC461110 SS+25d, EC48111003 SS+15d, HEC48S FF | 100% | EC48111005 | EC48111005 | 87A | 11 | 200 | E | E | C | EC48 | 1110 | ar | LND | IPR | 1101C22 |  |  |  |  |
| EC701110 |  | CA11 C.Bldg SK1101 - Structural Steel KM drwgs (Cladding + Support Drwgs) |  | 249d | 2010-03-08 A | 2011-02-28 A | EC48111004 SS+20d | 100% | EC701110 | EC701110 | 87A | 11 | 200 | E | E | C | EC70 | 1110 | de | LND | IPR | 1101N51 |  | N02K | N02K |  |
| EC501110 |  | CA11 C.Bldg - Architectural Det.drwgs Bldg AFC |  | 258d | 2010-03-30 A | 2011-04-04 A | EC701110 SS+16d, HEC50 FF, EC28111010 SS+10d, EC48111005 SS+10d | 100% | EC501110 | EC501110 | 87A | 11 | 200 | E | E | C | EC50 | 1110 | ar | LND | IPR | 1101C41 |  |  |  | 200 |
| EC45111010 |  | CA11 C.Bldg - Building Layout drwgs IFC | milestone | 0d | 2010-07-30 A | 2010-07-30 A | EC45111005 FF-14d | 100% | EC45111010 | EC45111010 | 87A | 11 | 200 | E | E | C | EC45 | 1110 | ar | LND | IPR |  |  |  |  |  |
|  | N | **N Structural Steel** |  |  | 2010-12-13 | 2011-05-16 |  |  |  |  |  |  |  |  |  |  |  |  |  |  |  |  |  |  |  |  |
| EN27111015 |  | CA11 C.Bldg SK1101- Check KM drwgs |  | 64d | 2010-12-13 A | 2011-03-14 A | EC701110 FF+10d | 100% | EN27111015 | EN27111015 | 87B | 11 | 200 |  | E | N | EN27 | 1110 | de | LND | LEI |  |  | N02K | N02K |  |
| EN28111005 |  | CA11 C.Bldg SK1101 - Shop dwgs(KMD) by Vend |  | 25d | 2011-04-12 A | 2011-05-16 A | EN27111015 FF+45d | 100% | EN28111005 | EN28111005 | 87B | 11 | 200 |  | E | N | EN28 | 1110 | de | LND | Chel |  |  | N02K | N02K |  |

Notes:
- EC421110: P3 Activity Log Info: fixed Layout
- EC441110: P3 Activity Log Info: incl. PMT approval
- EC221110: P3 Activity Log Info: TKB-B Keyplan to Subcontractor
- EC45111005: P3 Activity Log Info: incl. PMT approval
- EC45111010: P3 Activity Log Info: incl. PMT approval

| ID | WBS | Activity | Type | Duration | Start | Finish | Predecessors | Complete | Resources | Cost | Actual cost | UDF_SAVE ACTID | UDF_SAVE ACT ID | Department | Constr. Area | PMT-Area | PMT-Schedule Org | PMT-Discipline | PMT-Phase | PMT-Respons. | WBS Phase | WBS Discipline | WBS Type of Work | WBS Objects | IMS | UPT | TB26 Ressource Budget | Pro Unit/DocCode | Type of Work | Inquiry/Order No | PMT-Stage | Zeigen/n. Zeigen | PMT-Doc. Type |
| --- | --- | --- | --- | --- | --- | --- | --- | --- | --- | --- | --- | --- | --- | --- | --- | --- | --- | --- | --- | --- | --- | --- | --- | --- | --- | --- | --- | --- | --- | --- | --- | --- | --- |
|  | H | **H HVAC** |  |  | 2008-11-24 | 2010-08-05 |  |  |  |  |  |  |  |  |  |  |  |  |  |  |  |  |  |  |  |  |  |  |  |  |  |  |  |
| EH201110 |  | CA11 ComprBldg - HVAC&Plumbing / Feed/Basic |  | 165d | 2008-11-24 A | 2009-07-24 A | AD2230 FF+20d | 100% |  |  |  | EH201110 | EH201110 | 87C | 11 | 200 | 200 | 035 | E | LND | E | H | EH20 | 1110 | OTH | LND |  |  |  |  |  |  |  |
| EH30111005 |  | CA11 ComprBldg - HVAC Layouts Dwgs AFC |  | 132d | 2009-12-15 A | 2010-06-28 A | EH201110, HEH30 FF, P3C0BD | 100% | TKB-H [480 h] |  |  | EH30111005 | EH30111005 | 87C | 11 | 200 | 200 | 035 | E | IPR | E | H | EH30 | 1110 | OTH | LND | 480,00 | 1101H23 |  |  |  |  |  |
| EH40111005 |  | CA11 ComprBldg - HVAC Calculations&Flow Diagrams |  | 160d | 2009-12-15 A | 2010-08-05 A | EH30111005 SS | 100% | TKB-H [320 h] |  |  | EH40111005 | EH40111005 | 87C | 11 | 200 | 200 | 035 | E | IPR | E | H | EH40 | 1110 | OTH | LND | 320,00 | 1101H22 |  |  |  |  |  |
| EH071110 |  | CA11 ComprBldg - Issue of Dwgs&Doc's by RDI | level of effort | 72d | 2010-03-15 A | 2010-06-28 A | EH30111005 SS+60d, EH30111005 FF, EH40111010 FF | 100% | TKB-H [2784 h] |  |  | EH071110 | EH071110 | 87C | 11 | 200 | 200 | 035 | E | IPR | E | H | EH30 | 1110 | OTH | LND | 2784,00 |  |  |  |  |  |  |
| EH30111015 |  | CA11 ComprBldg - Review HVAC Layout Dwgs |  | 74d | 2010-03-31 A | 2010-07-16 A | EH30111010 | 100% | TKB-H [480 h] |  |  | EH30111015 | EH30111015 | 87C | 11 | 200 | 200 | 035 | E | LND | E | H | EH30 | 1110 | OTH | LND | 480,00 |  |  |  |  |  |  |
| EH40111010 |  | CA11 ComprBldg - HVAC Calc./Diagrams IFC | milestone | 0d | 2010-03-31 A | 2010-03-31 A | EH40111005 FF-16d | 100% |  |  |  | EH40111010 | EH40111010 | 87C | 11 | 200 | 200 | 035 | E | IPR | E | H | EH40 | 1110 | OTH | LND |  |  |  |  |  |  |  |
| EH30111010 |  | CA11 ComprBldg - HVAC Layouts Dwgs IFC | milestone | 0d | 2010-04-30 A | 2010-04-30 A | EH30111005 FF-11d | 100% |  |  |  | EH30111010 | EH30111010 | 87C | 11 | 200 | 200 | 035 | E | IPR | E | H | EH30 | 1110 | OTH | LND |  |  |  |  |  |  |  |
| EH051110 |  | CA11 ComprBldg - Final Loads f.Civil/StrSteel | milestone | 0d | 2010-06-22 A | 2010-06-22 A | EH30111005 FF-5d, E3H0150 SF | 100% |  |  |  | EH051110 | EH051110 | 87C | 11 | 200 |  |  |  | IPR | E | H | EH12 | 1110 | OTH | LND |  |  |  |  |  |  |  |
| EH241110 |  | CA11 ComprBldg - Wall & Floor opening details | milestone | 0d | 2010-06-22 A | 2010-06-22 A | HEH24 FF, E3H0150 SF, EH051110 FF | 100% |  |  |  | EH241110 | EH241110 | 87C | 11 | 200 | 200 | 035 | E | IPR | E | H | EH24 | 1110 | OTH | LND |  | 1101H21 |  |  |  |  |  |
|  | B | **B Mechanical - Stationary Equipment** |  |  | 2008-09-20 | 2008-09-20 |  |  |  |  |  |  |  |  |  |  |  |  |  |  |  |  |  |  |  |  |  |  |  |  |  |  |  |
| EB051110 |  | CA11 ComprBldg - Final Loads f.Civil/StrSteel | milestone | 0d | 2008-09-20 A | 2008-09-20 A | E3A1650 | 100% |  |  |  | EB051110 | EB051110 | 869 | 11 | 200 |  |  |  | LND | E | B | EB05 | 1110 | 3 | LND |  |  |  |  |  |  |  |
|  | M | **M Mechanical - Rotating Equipment** |  |  | 2008-03-14 | 2010-06-15 |  |  |  |  |  |  |  |  |  |  |  |  |  |  |  |  |  |  |  |  |  |  |  |  |  |  |  |
| E3M0320 |  | M03 Offgas Compr. - Techn. Eval./PO Spec. |  | 47d | 2008-03-14 A | 2008-05-23 A | P3M03C FF | 100% |  |  |  | E3M0320 | E3M0320 | 867 | 11 | 200 | 200 | 400 | E | LND | E | M | EM14 | 1110 | I | LND |  | DC | M03 | 2DC8460 | 3A | C2 |  |
| E3M0330 |  | M03 Offgas Compr. -Techn. Eval./Bid Tab F | milestone | 0d | 2008-05-10 A | 2008-05-10 A | F6490, P3M03C FF-5d | 100% |  |  |  | E3M0330 | E3M0330 | 867 | 11 | 200 | 200 | 055 | E | LND | E | M | EM14 | 1110 | I | LND |  |  | M03 | 2DC8460 |  | C2 |  |
| E3M0340 |  | M03 Offgas Compr. - 1st Review Vendor Dwgs |  | 19d | 2008-07-28 A | 2008-08-21 A | P3M03D FS+45d | 100% |  |  |  | E3M0340 | E3M0340 | 867 | 11 | 200 | 200 | 400 | E | LND | E | M | EM15 | 1110 | I | LND |  | DC | M03 | 2DC8460 | 3A | C2 | DFA |
| E3M0350 |  | M03 Offgas Compr. - Vendor dwgs approved | milestone | 0d | 2008-08-22 A | 2008-08-22 A | E3M0340 FF | 100% |  | 887,104 | 887,104 | E3M0350 | E3M0350 | 867 | 11 | 200 | 200 | 400 | E | LND | E | M | EM15 | 1110 | I | LND |  | DC | M03 | 2DC8460 |  | C2 |  |
| E3M0360 |  | M03 Offgas Compr. - 2nd Review Vendor Dwgs |  | 11d | 2008-09-05 A | 2008-09-19 A | E3M0340 FS+10d, E3M0350 | 100% |  |  |  | E3M0360 | E3M0360 | 867 | 11 | 200 | 200 | 400 | E | LND | E | M | EM15 | 1110 | I | LND |  | DC | M03 | 2DC8460 |  | C2 |  |
| EM051110 |  | CA11 ComprBldg - Final Loads f.Civil/StrSteel | milestone | 0d | 2008-09-20 A | 2008-09-20 A | E3M0340 | 100% |  |  |  | EM051110 | EM051110 | 867 | 11 | 200 |  |  |  | LND | E | M | EM05 | 1110 | I | LND |  |  |  |  |  |  |  |
| E3M0375 |  | M03 Offgas Compr. - KO / Re-Start Meeting | milestone | 0d | 2009-09-30 A | 2009-09-30 A | E3M0360 | 100% |  |  |  | E3M0375 | E3M0375 | 867 | 11 | 200 | 200 | 055 | E | LND | E | M | EM14 | 1110 | I | LND |  |  | M03 | 2DC8460 |  | C2 |  |
| E3M0325 |  | M03 Offgas Compr. - Rejustment PO Spec. |  | 30d | 2009-10-26 A | 2009-12-07 A | E3M0375 FS+30d | 100% | TAM [240 h] |  |  | E3M0325 | E3M0325 | 867 | 11 | 200 | 200 | 400 | E | LND | E | M | EM14 | 1110 | I | LND | 240,00 | DC | M03 | 2DC8460 | 3A | C2 |  |
| E3M0380 |  | M03 Offgas Compr. - Official Re-Start remaining/fabr. works | milestone | 0d | 2010-01-05 A | 2010-01-05 A | E3M0375 FF+65d | 100% |  |  |  | E3M0380 | E3M0380 | 867 | 11 | 200 | 200 | 055 | E | LND | E | M | EM14 | 1110 | I | LND |  |  | M03 | 2DC8460 |  | C2 |  |
| E3M0365 |  | M03 Offgas Compr. - 2nd Review Rejustment Vendor Dwgs |  | 71d | 2010-01-13 A | 2010-04-23 A | E3M0325, E3M0375 FS+70d | 100% | TAM [1120 h] |  |  | E3M0365 | E3M0365 | 867 | 11 | 200 | 200 | 400 | E | LND | E | M | EM15 | 1110 | I | LND | 1120,00 | DC | M03 | 2DC8460 |  | C2 |  |
| P3M0370 |  | M03 Offgas Compr. - Review Lube Oil Unit Vendor Dwgs |  | 15d | 2010-05-26 A | 2010-06-15 A | E3M0365 FS+20d | 100% |  |  |  | P3M0370 | P3M0370 | 867 | 11 | 200 | 200 | 400 | E | LND | E | M | EM15 | 1110 | I | LND |  | DC | M03 | 2DC8460 |  | C2 |  |

Notes:
- E3M0350: Expenses: 900A 887104

| ID | WBS | Activity | Type | Duration | Start | Finish | Predecessors | Complete | Resources | UDF_SAVE ACTID | UDF_SAVE ACT ID | Department | Constr. Area | PMT-Area | PMT-Respons. | WBS Phase | WBS Discipline | WBS Type of Work | WBS Objects | IMS | UPT | UDF_CONTRACT START DATE | UDF_CONTRACT FINISH DATE | UDF_CONTRACT ITEM | PMT-Phase | TB26 Ressource Budget | Pro Unit/DocCode | PMT-Schedule Org |
| --- | --- | --- | --- | --- | --- | --- | --- | --- | --- | --- | --- | --- | --- | --- | --- | --- | --- | --- | --- | --- | --- | --- | --- | --- | --- | --- | --- | --- |
|  | R | **R Piping** |  |  | 2008-04-01 | 2011-01-07 |  |  |  |  |  |  |  |  |  |  |  |  |  |  |  |  |  |  |  |  |  |  |
| ER151110 |  | CA11 ComprBldg - Conceptual Piping |  | 169d | 2008-04-01 A | 2008-11-28 A | F2760 | 100% |  | ER151110 | ER151110 | 876 | 11 | 200 | LND | E | R | ER15 | 1110 | PL | LND |  |  |  |  |  |  |  |
| ER301110 |  | CA11 ComprBldg - CAD Model Piping / Equipment |  | 517d | 2008-07-01 A | 2010-07-23 A | ER391110 FF+10d, E3R100 FF, ER151110 SS | 100% |  | ER301110 | ER301110 | 876 | 11 | 200 | LNI | E | R | ER30 | 1110 | PL | LND |  |  |  |  |  |  |  |
| ER161110 |  | CA11 ComprBldg - prelim Loads for Steel Struc |  | 20d | 2009-01-05 A | 2009-01-30 A | ER151110 FF | 100% |  | ER161110 | ER161110 | 876 | 11 | 200 | LND | E | R | ER16 | 1110 | PL | LND |  |  |  |  |  |  |  |
| ER361110 |  | CA11 ComprBldg - CAD Model Review 60% |  | 12d | 2009-11-02 A | 2009-11-17 A | F4030 SS | 100% |  | ER361110 | ER361110 | 876 | 11 | 200 | LND | E | R | ER36 | 1110 | 2 | LND |  |  |  |  |  |  |  |
| ER421110 |  | CA11 ComprBldg - Stress Calculation |  | 98d | 2009-11-16 A | 2010-04-09 A | ER361110 | 100% |  | ER421110 | ER421110 | 872 | 11 | 200 | LND | E | R | ER42 | 1110 | PL | LND |  |  |  |  |  |  |  |
| ER191110 |  | CA11 ComprBldg - Final Loads for Steel Struc | milestone | 0d | 2010-01-04 A | 2010-01-04 A | EN21111010 FF-5d, ER161110 FF, F4030 SF+20d | 100% |  | ER191110 | ER191110 | 876 | 11 | 200 | LNI | E | R | ER19 | 1110 | PL | LND |  |  |  |  |  |  |  |
| ER391110 |  | CA11 ComprBldg - CAD Model Review 90% |  | 10d | 2010-06-28 A | 2010-07-09 A | F4460 FF | 100% |  | ER391110 | ER391110 | 876 | 11 | 200 | LND | E | R | ER39 | 1110 | 3 | LND |  |  |  |  |  |  |  |
| ER451110 |  | CA11 ComprBldg - Piping Isometrics |  | 107d | 2010-07-12 A | 2010-12-08 A | ER421110, ER391110 FF+30d, ER451304 SS, ER301110 FF+20d | 100% |  | ER451110 | ER451110 | 876 | 11 | 200 | LEI | E | R | ER45 | 1110 | 5 | LND |  |  |  |  |  |  |  |
| ER491110 |  | CA11 ComprBldg - Design Check / Rel.Isos & BOM |  | 92d | 2010-08-30 A | 2011-01-07 A | ER451110 FF | 100% |  | ER491110 | ER491110 | 876 | 11 | 200 | LEI | E | R | ER49 | 1110 | 5 | LND |  |  |  |  |  |  |  |
|  | E | **E Electrical** |  |  | 2008-10-06 | 2010-07-30 |  |  |  |  |  |  |  |  |  |  |  |  |  |  |  |  |  |  |  |  |  |  |
| EE46111005 |  | CA11 ComprBldg - prelimLoads f.Civil / StrSteel |  | 15d | 2008-10-06 A | 2008-10-24 A | F3060 FF | 100% |  | EE46111005 | EE46111005 | 874 | 11 |  | LND | E | E | EE11 | 1110 | E | LND | 2011-05-10 | 2011-11-30 | E-16-07-01 | E |  |  |  |
| EE901110 |  | CA11 ComprBldg - Earthing Details |  | 30d | 2009-05-07 A | 2009-06-19 A | HEE90 FF, EE901201 SS | 100% |  | EE901110 | EE901110 | 874 | 11 |  | LND | E | E | EE90 | 1110 | E | LND | 2011-05-10 | 2011-11-30 | E-16-07-01 | E |  |  |  |
| EE46111010 |  | CA11 ComprBldg - El. CableTray Layout Pl. / LOP's 1st Issue |  | 162d | 2009-12-07 A | 2010-07-30 A | HEE36 FF, IMS-E-000190 SS, IMS-E-000190 FF, F4030 FF+75d, EE360260 SS, EE460000 | 100% |  | EE46111010 | EE46111010 | 874 | 11 |  | LEI | E | E | EE46 | 1110 | E | LND | 2011-05-10 | 2011-11-30 | E-16-07-01 | E |  |  |  |
| EE561110 |  | CA11 ComprBldg - Cable Pulling Details |  | 159d | 2009-12-10 A | 2010-07-30 A | EE46111010 FF, EE500130 | 100% |  | EE561110 | EE561110 | 874 | 11 |  | LEI | E | E | EE56 | 1110 | E | LND | 2011-05-10 | 2011-11-30 | E-16-07-01 | E |  |  |  |
| EE46111008 |  | CA11 ComprBldg - Final Loads f.Civil / StrSteel |  | 45d | 2009-12-14 A | 2010-02-18 A | EE46111005 | 100% |  | EE46111008 | EE46111008 | 874 | 11 |  | LEI | E | E | EE12 | 1110 | E | LND | 2011-05-10 | 2011-11-30 | E-16-07-01 | E |  |  |  |
| EE761110 |  | CA11 ComprBldg - Layout Plan Lighting & Sockets 1st Issue |  | 104d | 2010-01-26 A | 2010-06-24 A | EC501110 SF+10d, HEE76 FF, EE000180 | 100% | TAE [1952 h] | EE761110 | EE761110 | 874 | 11 |  | LEI | E | E | EE76 | 1110 | E | LND | 2011-05-10 | 2011-11-30 | E-16-07-01 | E | 1952,00 |  |  |
|  | J | **J Instrumentation** |  |  | 2008-10-06 | 2010-11-26 |  |  |  |  |  |  |  |  |  |  |  |  |  |  |  |  |  |  |  |  |  |  |
| EJ46111005 |  | CA11 ComprBldg - prelimLoads f.Civil/StrSteel |  | 15d | 2008-10-06 A | 2008-10-24 A | F3060 FF | 100% |  | EJ46111005 | EJ46111005 | 86E | 11 |  | LND | E | J | EJ11 | 1110 | I | LND |  |  |  | E |  | 999 |  |
| EJ361110 |  | CA11 ComprBldg - Hook-Up drwgs 1st Issue |  | 90d | 2010-02-03 A | 2010-06-14 A | IMS-E-000210 FF, F4030 FS+50d, HEJ36 FF | 100% |  | EJ361110 | EJ361110 | 86E | 11 | 200 | LEI | E | J | EJ36 | 1110 | I | LND |  |  |  | C |  | 999 | 200 |
| EJ46111010 |  | CA11 ComprBldg - Instr Cable Tray Layout Pl. 1st Issue |  | 106d | 2010-03-01 A | 2010-07-30 A | IMS-E-000210 FF, HEJ46 FF, EE46111010 FF, F4030 FF | 100% |  | EJ46111010 | EJ46111010 | 86E | 11 |  | LEI | E | J | EJ41 | 1110 | I | LND |  |  |  | E |  | 999 |  |
| EJ46111008 |  | CA11 ComprBldg - Final Loads f.Civil/StrSteel |  | 10d | 2010-05-03 A | 2010-05-17 A | EJ46111005, HEJ12 FF | 100% |  | EJ46111008 | EJ46111008 | 86E | 11 |  | LEI | E | J | EJ12 | 1110 | I | LND |  |  |  | E |  | 999 |  |
| EJ321110 |  | CA11 ComprBldg - JB Location drwgs |  | 25d | 2010-07-12 A | 2010-08-13 A | F4460 FF+25d, HEJ37 FF, F4030, IMS-E-000210 FF | 100% |  | EJ321110 | EJ321110 | 86E | 11 | 200 | LEI | E | J | EJ37 | 1110 | I | LND |  |  |  | C |  | 999 | 200 |
| EJ360010 |  | General - Hook-Up drwgs final Issue |  | 72d | 2010-08-18 A | 2010-11-26 A | EJ361201 FS+30d, EJ361710 FS+35d, EJ361301 FS+30d, EJ363110 FS+30d | 100% |  | EJ360010 | EJ360010 | 86E | 11 | 200 | LEI | E | J | EJ36 | 1110 | I | LND |  |  |  | C |  | 999 | 200 |
| EJ800010 |  | Input Yokogawa I/O Assignment DCS/SIS | milestone | 0d | 2010-08-19 A | 2010-08-19 A | P3J06D3, P3J06D2 | 100% |  | EJ800010 | EJ800010 | 86E | 11 |  | YGW | E | J | EJ80 | 1110 | I | LND |  |  |  | E |  | 999 |  |
| EJ801110 |  | CA11 ComprBldg - Loop Diagrams |  | 70d | 2010-08-20 A | 2010-11-26 A | EJ800010, IMS-E-000210 FF, A1EJ0040 SF, HEJ80 FF | 100% |  | EJ801110 | EJ801110 | 86E | 11 |  | LEI | E | J | EJ80 | 1110 | I | LND |  |  |  | E |  | 999 |  |

Notes:
- EE561110: P3 Activity Log Info: UG/Above Ground Details

| ID | WBS | Activity | Type | Duration | Start | Finish | Predecessors | Complete | Resources | UDF_SAVE ACTID | UDF_SAVE ACT ID | Department | Constr. Area | Pro Unit/DocCode | PMT-Area | PMT-Phase | PMT-Respons. | WBS Phase | WBS Discipline | WBS Type of Work | WBS Objects | IMS | UPT | PMT-Schedule Org | Type of Work | Inquiry/Order No | PMT-Discipline | Zeigen/n. Zeigen | TB26 Ressource Budget |
| --- | --- | --- | --- | --- | --- | --- | --- | --- | --- | --- | --- | --- | --- | --- | --- | --- | --- | --- | --- | --- | --- | --- | --- | --- | --- | --- | --- | --- | --- |
|  | 1111 | **1111 Offgas Compressor Filter Section - CA11** |  |  | 2008-03-03 | 2011-01-07 |  |  |  |  |  |  |  |  |  |  |  |  |  |  |  |  |  |  |  |  |  |  |  |
|  | C | **C Civil** |  |  | 2009-10-26 | 2010-06-09 |  |  |  |  |  |  |  |  |  |  |  |  |  |  |  |  |  |  |  |  |  |  |  |
| EC241111 |  | CA11 OffgComprFilt - Layout Drwg / Loads IFD |  | 15d | 2009-10-26 A | 2009-11-13 A | EB051111, EN251111 FF | 100% |  | EC241111 | EC241111 | 87A | 11 | 1111C01 | 200 | E | LND | E | C | EC24 | 1111 | de | LND |  |  |  |  |  |  |
| EC261111 |  | CA11 OffgComprFilt - Civil Static Calc (Piling) |  | 104d | 2010-01-11 A | 2010-06-09 A | P3C0BD FS+15d, EC461110 SS, EC241111 | 100% |  | EC261111 | EC261111 | 87A | 11 | 1111C14 | 200 | E | IPR | E | C | EC26 | 1111 | de | LND |  |  |  |  |  |  |
| EC45111105 |  | CA11 OffgComprFilt - Civil Layout drwgs AFC |  | 104d | 2010-01-11 A | 2010-06-09 A | P3C0BD FS+10d, EC261111 SS, AD2230, EC241111, HEC45C FF | 100% |  | EC45111105 | EC45111105 | 87A | 11 | 1111C13 | 200 | E | IPR | E | C | EC45 | 1111 | ar | LND |  |  |  |  |  |  |
| EC151111 |  | CA11 OffgComprFilt - Piling drwgs AFC |  | 80d | 2010-01-18 A | 2010-05-11 A | EC261111 SS+5d, HEC15 FF | 100% |  | EC151111 | EC151111 | 87A | 11 | 1111C16 | 200 | E | IPR | E | C | EC15 | 1111 | PI | LND |  |  |  |  |  |  |
| EC281111 |  | CA11 OffgComprFilt - Formw/Reinforce drwgs AFC |  | 84d | 2010-02-08 A | 2010-06-09 A | EC151111 SS+15d, EC261111 SS+20d | 100% |  | EC281111 | EC281111 | 87A | 11 | 1111C21 | 200 | E | IPR | E | C | EC28 | 1111 | cq | LND | 200 |  |  |  |  |  |
| EC45111110 |  | CA11 OffgComprFilt - Civil Layout drwgs IFC | milestone | 0d | 2010-05-11 A | 2010-05-11 A | EC45111105 FF-14d | 100% |  | EC45111110 | EC45111110 | 87A | 11 |  | 200 | E | IPR | E | C | EC45 | 1111 | ar | LND |  |  |  |  |  |  |
|  | N | **N Structural Steel** |  |  | 2008-03-03 | 2010-12-13 |  |  |  |  |  |  |  |  |  |  |  |  |  |  |  |  |  |  |  |  |  |  |  |
| EN151111 |  | CA11 OffgComprFilt SK1104- CAD Model/Concepts StrSteel |  | 126d | 2008-03-03 A | 2008-08-29 A | AD2230 FF | 100% |  | EN151111 | EN151111 | 87B | 11 |  | 200 | E | LND | E | N | EN15 | 1111 | de | LND | 200 | N02* | N02* | 055 | 0 |  |
| EN21111105 |  | CA11 OffgComprFilt SK1104 - GA-Drwgs + Fdtn Loads |  | 15d | 2009-03-23 A | 2009-04-14 A | ER161111, AD2230 FS+60d, EE46111105, EN151111 FF, EJ46111105 | 100% |  | EN21111105 | EN21111105 | 87B | 11 |  | 200 |  | LEI | E | N | EN21 | 1111 | de | LND |  | N02* | N02* |  |  |  |
| EN24111105 |  | CA11 OffgComprFilt SK1104 - StaticCalc f.Fdtn Load |  | 15d | 2009-09-10 A | 2009-09-30 A | EN21111105 FS+20d, E3A0120 SF | 100% |  | EN24111105 | EN24111105 | 87B | 11 |  | 200 |  | LND | E | N | EN24 | 1111 | de | LND |  | N02* | N02* |  |  |  |
| EN251111 |  | CA11 OffgComprFilt SK1104 - Loads for Civil | milestone | 0d | 2009-11-13 A | 2009-11-13 A | HEN25 FF, EN24111105 FF+32d | 100% |  | EN251111 | EN251111 | 87B | 11 |  | 200 | E | LND | E | N | EN25 | 1111 | de | LND | 200 | N02* | N02* | 055 | 0 |  |
| EN21111110 |  | CA11 OffgComprFilt SK1104 - GA-Drwgs + Final Loads |  | 15d | 2010-01-11 A | 2010-01-29 A | EN21111105 FS+10d, EE46111108 FF+7d, EN24111105, EN251111 FS+35d, EB051130, HEN21 FF, EJ46111108 | 100% | TKB-S [320 h] | EN21111110 | EN21111110 | 87B | 11 |  | 200 |  | LEI | E | N | EN21 | 1111 | de | LND |  | N02* | N02* |  |  | 320,00 |
| EN24111110 |  | CA11 OffgComprFilt SK1104 - Final Static Calc |  | 121d | 2010-01-25 A | 2010-07-16 A | EN21111110, ER191111 FF | 100% | TKB-S [320 h] | EN24111110 | EN24111110 | 87B | 11 |  | 200 |  | LEI | E | N | EN24 | 1111 | de | LND |  | N02* | N02* |  |  | 320,00 |
| EN261111 |  | CA11 OffgComprFilt SK1104 - Layout dwgs input for KM dwgs |  | 49d | 2010-05-19 A | 2010-07-27 A | EN24111110 FF, F4030 FF+20d, HEN26 FF | 100% | TKB-S [480 h] | EN261111 | EN261111 | 87B | 11 |  | 200 |  | LEI | E | N | EN26 | 1111 | st | LND |  | N02* | N02* |  |  | 480,00 |
| EN671111 |  | CA11 OffgComprFilt SK1104 - Grating Cut-Out drwgs |  | 70d | 2010-06-21 A | 2010-09-24 A | ER421111 FF, EN261111 FF+10d, F4460 FF+10d | 100% | TKB-S [240 h] | EN671111 | EN671111 | 87B | 11 |  | 200 | C | LEI | E | N | EN67 | 1111 | de | LND | 200 | N02* | N02* |  |  | 240,00 |
| EN27111105 |  | CA11 OffgComprFilt SK1104 - KM drwgs |  | 38d | 2010-07-28 A | 2010-09-17 A | EN24111105, P3N01D FS+1d, EN261111 | 100% | KM Drwgs preparation by Cheljabinsk [37 t] | EN27111105 | EN27111105 | 87B | 11 |  | 200 |  | Chel | E | N | EN27 | 1111 | de | LND |  | N02* | N02* |  |  | 0,00 |
| EN27111110 |  | CA11 OffgComprFilt SK1104 - Check KM drwgs |  | 30d | 2010-08-25 A | 2010-10-05 A | EN27111105 | 100% |  | EN27111110 | EN27111110 | 87B | 11 |  | 200 |  | LEI | E | N | EN27 | 1111 | de | LND |  | N02* | N02* |  |  |  |
| EN281111 |  | CA11 OffgComprFilt SK1104 - Shop dwgs(KMD) by Vend |  | 48d | 2010-10-06 A | 2010-12-13 A | HEN28 FF, EN27111110 | 100% |  | EN281111 | EN281111 | 87B | 11 |  | 200 |  | Chel | E | N | EN28 | 1111 | de | LND |  | N02* | N02* |  |  |  |
| EN641111 |  | CACA11 OffgComprFilt SK1104 - Check Grating Cut-Out drwgs |  | 5d | 2010-10-06 A | 2010-10-12 A | EN671111 | 100% |  | EN641111 | EN641111 | 87B | 11 |  | 200 | C | LEI | E | N | EN67 | 1111 | de | LND | 200 | N02* | N02* |  |  |  |
| EN681111 |  | CA11 OffgComprFilt SK1104 - Grating Fabrication drwgs |  | 20d | 2010-10-06 A | 2010-11-02 A | HEN68 FF, EN671111 | 100% | TKB-S [80 h] | EN681111 | EN681111 | 87B | 11 |  | 200 | C | Chel | E | N | EN68 | 1111 | de | LND | 200 | N02* | N02* |  |  | 80,00 |
|  | B | **B Mechanical - Stationary Equipment** |  |  | 2008-11-26 | 2008-11-26 |  |  |  |  |  |  |  |  |  |  |  |  |  |  |  |  |  |  |  |  |  |  |  |
| EB051111 |  | CA11 OffgComprFilt - Final Loads for Struc Steel | milestone | 0d | 2008-11-26 A | 2008-11-26 A | E3A1660 FF | 100% |  | EB051111 | EB051111 | 869 | 11 |  | 200 |  | LND | E | B | EB05 | 1111 | 3 | LND |  |  |  |  |  |  |

Notes:
- EC45111105: P3 Activity Log Info: incl. PMT approval
- EC45111110: P3 Activity Log Info: incl. PMT approval

| ID | WBS | Activity | Type | Duration | Start | Finish | Predecessors | Complete | Resources | Cost | Actual cost | UDF_SAVE ACTID | UDF_SAVE ACT ID | Department | Constr. Area | PMT-Area | PMT-Respons. | WBS Phase | WBS Discipline | WBS Type of Work | WBS Objects | IMS | UPT | UDF_CONTRACT START DATE | UDF_CONTRACT FINISH DATE | UDF_CONTRACT ITEM | PMT-Phase | Pro Unit/DocCode | PMT-Schedule Org | Type of Work | Inquiry/Order No | PMT-Discipline | PMT-Doc. Type | Zeigen/n. Zeigen | PMT-Stage | TB26 Ressource Budget |
| --- | --- | --- | --- | --- | --- | --- | --- | --- | --- | --- | --- | --- | --- | --- | --- | --- | --- | --- | --- | --- | --- | --- | --- | --- | --- | --- | --- | --- | --- | --- | --- | --- | --- | --- | --- | --- |
|  | R | **R Piping** |  |  | 2008-04-01 | 2011-01-07 |  |  |  |  |  |  |  |  |  |  |  |  |  |  |  |  |  |  |  |  |  |  |  |  |  |  |  |  |  |  |
| ER151111 |  | CA11 OffgComprFilt - Conceptual Piping |  | 169d | 2008-04-01 A | 2008-11-28 A | F2760 | 100% |  |  |  | ER151111 | ER151111 | 876 | 11 | 200 | LND | E | R | ER15 | 1111 | PL | LND |  |  |  |  |  |  |  |  |  |  |  |  |  |
| ER301111 |  | CA11 OffgComprFilt - CAD Model Piping / Eqpt |  | 517d | 2008-07-01 A | 2010-07-23 A | ER391111 FF+10d, ER151111 SS | 100% |  |  |  | ER301111 | ER301111 | 876 | 11 | 200 | LNI | E | R | ER30 | 1111 | PL | LND |  |  |  |  |  |  |  |  |  |  |  |  |  |
| ER161111 |  | CA11 OffgComprFilt - prelim Loads for SteelStruc |  | 20d | 2009-01-05 A | 2009-01-30 A | ER151111 FF | 100% |  |  |  | ER161111 | ER161111 | 876 | 11 | 200 | LND | E | R | ER16 | 1111 | PL | LND |  |  |  |  |  |  |  |  |  |  |  |  |  |
| ER361111 |  | CA11 OffgComprFilt - CAD Model Review 60% |  | 12d | 2009-11-02 A | 2009-11-17 A | F4030 SS | 100% |  |  |  | ER361111 | ER361111 | 876 | 11 | 200 | LND | E | R | ER36 | 1111 | 2 | LND |  |  |  |  |  |  |  |  |  |  |  |  |  |
| ER421111 |  | CA11 OffgComprFilt - Stress Calculation |  | 103d | 2009-11-16 A | 2010-04-16 A | ER361111 | 100% |  |  |  | ER421111 | ER421111 | 872 | 11 | 200 | LND | E | R | ER42 | 1111 | PL | LND |  |  |  |  |  |  |  |  |  |  |  |  |  |
| ER191111 |  | CA11 OffgComprFilt - Final Loads for SteelStruc | milestone | 0d | 2010-01-04 A | 2010-01-04 A | EN21111110 FF, ER161111 FF, F4030 SF+20d | 100% |  |  |  | ER191111 | ER191111 | 876 | 11 | 200 | LNI | E | R | ER19 | 1111 | PL | LND |  |  |  |  |  |  |  |  |  |  |  |  |  |
| ER391111 |  | CA11 OffgComprFilt - CAD Model Review 90% |  | 10d | 2010-06-28 A | 2010-07-09 A | F4460 FF | 100% |  |  |  | ER391111 | ER391111 | 876 | 11 | 200 | LND | E | R | ER39 | 1111 | 3 | LND |  |  |  |  |  |  |  |  |  |  |  |  |  |
| ER451111 |  | CA11 OffgComprFilt - Piping Isometrics |  | 98d | 2010-07-23 A | 2010-12-08 A | ER301111 FF+20d, ER391111 FS+5d, ER421111 | 100% |  |  |  | ER451111 | ER451111 | 876 | 11 | 200 | LEI | E | R | ER45 | 1111 | 5 | LND |  |  |  |  |  |  |  |  |  |  |  |  |  |
| ER491111 |  | CA11 OffgComprFilt - Design Check / Rel.Isos&BOM |  | 92d | 2010-08-30 A | 2011-01-07 A | ER451111 FF | 100% |  |  |  | ER491111 | ER491111 | 876 | 11 | 200 | LEI | E | R | ER49 | 1111 | 5 | LND |  |  |  |  |  |  |  |  |  |  |  |  |  |
|  | E | **E Electrical** |  |  | 2008-10-06 | 2010-06-24 |  |  |  |  |  |  |  |  |  |  |  |  |  |  |  |  |  |  |  |  |  |  |  |  |  |  |  |  |  |  |
| EE46111105 |  | CA11 OffgComprFilt - prelimLoads f.Struc Steel |  | 15d | 2008-10-06 A | 2008-10-24 A | F3060 FF | 100% |  |  |  | EE46111105 | EE46111105 | 874 | 11 |  | LND | E | E | EE11 | 1111 | E | LND | 2011-05-10 | 2011-11-30 | E-16-07-01 | E |  |  |  |  |  |  |  |  |  |
| EE901111 |  | CA11 OffgComprFilt - Earthing Details |  | 30d | 2009-06-22 A | 2009-07-31 A | EE901201, HEE90 FF | 100% |  |  |  | EE901111 | EE901111 | 874 | 11 |  | LND | E | E | EE90 | 1111 | E | LND | 2011-05-10 | 2011-11-30 | E-16-07-01 | E |  |  |  |  |  |  |  |  |  |
| EE46111108 |  | CA11 OffgComprFilt - Final Loads f.Struc Steel |  | 30d | 2009-11-24 A | 2010-01-08 A | EE46111105 | 100% |  |  |  | EE46111108 | EE46111108 | 874 | 11 |  | LEI | E | E | EE12 | 1111 | E | LND | 2011-05-10 | 2011-11-30 | E-16-07-01 | E |  |  |  |  |  |  |  |  |  |
| EE761111 |  | CA11 OffgComprFilt - Layout Plan Light.&Sockets 1st Issue |  | 104d | 2010-01-26 A | 2010-06-24 A | EE000180 FS+10d | 100% |  |  |  | EE761111 | EE761111 | 874 | 11 |  | LEI | E | E | EE76 | 1111 | E | LND | 2011-05-10 | 2011-11-30 | E-16-07-01 | E |  |  |  |  |  |  |  |  |  |
|  | J | **J Instrumentation** |  |  | 2008-10-06 | 2010-11-26 |  |  |  |  |  |  |  |  |  |  |  |  |  |  |  |  |  |  |  |  |  |  |  |  |  |  |  |  |  |  |
| EJ46111105 |  | CA11 OffgComprFilt - prelim Loads f.Struc Steel |  | 15d | 2008-10-06 A | 2008-10-24 A | F3060 FF | 100% |  |  |  | EJ46111105 | EJ46111105 | 86E | 11 |  | LND | E | J | EJ11 | 1111 | I | LND |  |  |  | E | 999 |  |  |  |  |  |  |  |  |
| EJ46111108 |  | CA11 OffgComprFilt - Final Loads f.Struc Steel |  | 10d | 2010-01-04 A | 2010-01-15 A | EJ46111105 | 100% |  |  |  | EJ46111108 | EJ46111108 | 86E | 11 |  | LEI | E | J | EJ12 | 1111 | I | LND |  |  |  | E | 999 |  |  |  |  |  |  |  |  |
| EJ361111 |  | CA11 OffgComprFilt - Hook-Up drwgs 1st Issue |  | 90d | 2010-02-03 A | 2010-06-14 A | F4030 FS+50d, A1EJ0080 | 100% |  |  |  | EJ361111 | EJ361111 | 86E | 11 | 200 | LEI | E | J | EJ36 | 1111 | I | LND |  |  |  | C | 999 | 200 |  |  |  |  |  |  |  |
| EJ321111 |  | CA11 OffgComprFilt - JB Location drwgs |  | 25d | 2010-07-12 A | 2010-08-13 A | F4030, F4460 FF+25d | 100% |  |  |  | EJ321111 | EJ321111 | 86E | 11 | 200 | LEI | E | J | EJ37 | 1111 | I | LND |  |  |  | C | 999 | 200 |  |  |  |  |  |  |  |
| EJ801111 |  | CA11 OffgComprFilt - Loop Diagrams |  | 70d | 2010-08-20 A | 2010-11-26 A | A1EJ0040 SF, EJ800010 | 100% |  |  |  | EJ801111 | EJ801111 | 86E | 11 |  | LEI | E | J | EJ80 | 1111 | I | LND |  |  |  | E | 999 |  |  |  |  |  |  |  |  |
|  | 12 | **12 CA12 - Polymerization Line 1** |  |  | 2008-01-25 | 2011-10-18 |  |  |  |  |  |  |  |  |  |  |  |  |  |  |  |  |  |  |  |  |  |  |  |  |  |  |  |  |  |  |
|  | LUZ2 | **LUZ2 General ( )** |  |  | 2008-02-18 | 2011-05-06 |  |  |  |  |  |  |  |  |  |  |  |  |  |  |  |  |  |  |  |  |  |  |  |  |  |  |  |  |  |  |
|  | B | **B Mechanical - Stationary Equipment** |  |  | 2008-02-20 | 2011-05-06 |  |  |  |  |  |  |  |  |  |  |  |  |  |  |  |  |  |  |  |  |  |  |  |  |  |  |  |  |  |  |
| E3A0110 |  | A01 Drums/Small Vessels - Inquiry Spec. |  | 11d | 2008-02-20 A | 2008-03-05 A | F1670 SS | 100% |  |  |  | E3A0110 | E3A0110 | 869 | 12 | 200 | LND | E | B | EB13 | LUZ2 | INS | LND |  |  |  | E |  | 200 | A01 | 2DD8530 | 055 | DEV | 0 |  |  |
| E3A0420 |  | A04 R Overhead Separ. - Techn. Eval./PO Spec |  | 64d | 2008-03-17 A | 2008-06-18 A | P3A04C FF | 100% |  |  |  | E3A0420 | E3A0420 | 869 | 12 | 200 | LND | E | B | EB14 | LUZ2 | 3 | LND |  |  |  | E | DC | 200 | A04 | 2DC8500 | 400 |  | C2 |  |  |
| E3A0520 |  | A05 Offgas Cyclone&R - Techn. Eval./PO Spec |  | 41d | 2008-03-26 A | 2008-05-23 A | P3A05C FF | 100% |  |  |  | E3A0520 | E3A0520 | 869 | 12 | 200 | LND | E | B | EB14 | LUZ2 | 3 | LND |  |  |  | E | DC | 200 | A05 | 2DC8590 | 400 |  | C2 | 3A |  |
| E3A0720 |  | A07 R Fines Eductor - Techn. Eval./PO Spec. |  | 52d | 2008-04-21 A | 2008-07-03 A | P3A07C FF | 100% |  |  |  | E3A0720 | E3A0720 | 869 | 12 | 200 | LND | E | B | EB94 | LUZ2 | 3 | LND |  |  |  | E | DC | 200 | A07 | 2DC8640 | 400 |  | C2 | 3A |  |
| E3A0530 |  | A05 Offgas Cyclone&R - Techn. Eval./Bid Tab Fina | milestone | 0d | 2008-05-01 A | 2008-05-01 A | P3A05C FF-4d, F7090 | 100% |  |  |  | E3A0530 | E3A0530 | 869 | 12 | 200 | LND | E | B | EB14 | LUZ2 | 3 | LND |  |  |  | E | DC | 200 | A05 | 2DC8590 | 400 |  | C2 | 3A |  |
| E3A0610 |  | A06 Start-Up Heater/Condenser - Inquiry Spec. |  | 10d | 2008-05-09 A | 2008-05-23 A | F1670 SS+55d | 100% |  |  |  | E3A0610 | E3A0610 | 869 | 12 | 200 | LND | E | B | EB23 | LUZ2 | 3 | LND |  |  |  | E |  | 200 | A06 | 2DD8530 | 055 | DEV | 0 |  |  |
| E3A0430 |  | A04 R Overhead Separ. - Techn. Eval./Bid Tab Fin | milestone | 0d | 2008-06-04 A | 2008-06-04 A | F8540, E3A0420 FF-7d | 100% |  |  |  | E3A0430 | E3A0430 | 869 | 12 | 200 | LND | E | B | EB14 | LUZ2 | 3 | LND |  |  |  | E | DC | 200 | A04 | 2DC8500 | 400 |  | C2 |  |  |
| E3A0730 |  | A07 R Fines Eductor - Techn. Eval./Bid Tab Final | milestone | 0d | 2008-06-21 A | 2008-06-21 A | P3A07C FF-5d, F5190 SF | 100% |  |  |  | E3A0730 | E3A0730 | 869 | 12 | 200 | LND | E | B | EB94 | LUZ2 | 3 | LND |  |  |  | E | DC | 200 | A07 | 2DC8640 | 400 |  | C2 | 3A |  |
| E3A1110 |  | A11 Unloading Arms - Inquiry Spec. |  | 7d | 2008-07-01 A | 2008-07-09 A | F1670 SS+90d | 100% |  |  |  | E3A1110 | E3A1110 | 869 | 12 | 200 | LND | E | B | EB93 | LUZ2 | 3 | LND |  |  |  | E |  | 200 | A11 | 2KB4420 | 055 | DEV | 0 |  |  |
| E3A0740 |  | A07 R Fines Eductor - 1st Review Vendor Dwgs |  | 9d | 2008-08-04 A | 2008-08-14 A | P3A07D1 FS+18d | 100% |  |  |  | E3A0740 | E3A0740 | 869 | 12 | 200 | LND | E | B | EB95 | LUZ2 | 3 | LND |  |  |  | E | DC | 200 | A07 | 2DC8640 | 400 | DFA | C2 | 3A |  |
| E3A04A20 |  | A04A R Overhead Cond. - Techn. Eval./PO Spec |  | 50d | 2008-08-07 A | 2008-10-16 A | F5310, P3A04AC FF | 100% |  |  |  | E3A04A20 | E3A04A20 | 869 | 12 | 200 | LND | E | B | EB14 | LUZ2 | 3 | LND |  |  |  | E | DC | 200 | A04A | 2DC9110 | 400 |  | C2 | 3A |  |
| E3A0440 |  | A04 R Overhead Separ. - 1st Review Vendor Dwgs |  | 18d | 2008-08-13 A | 2008-09-05 A | P3A04D FS+35d | 100% |  |  |  | E3A0440 | E3A0440 | 869 | 12 | 200 | LND | E | B | EB15 | LUZ2 | 3 | LND |  |  |  | E | DC | 200 | A04 | 2DC8500 | 400 | DFA | C2 |  |  |
| E3A0550 |  | A05 Offgas Cyclone&R - Vendor dwgs approved | milestone | 0d | 2008-08-15 A | 2008-08-15 A | E3A0540 FF | 100% |  | 71,648.8 | 71,648.8 | E3A0550 | E3A0550 | 869 | 12 | 200 | LND | E | B | EB15 | LUZ2 | 3 | LND |  |  |  | E | DC | 200 | A05 | 2DC8590 | 400 |  | C2 |  |  |
| E3A0750 |  | A07 R Fines Eductor - Vendor dwgs approved | milestone | 0d | 2008-08-15 A | 2008-08-15 A | E3A0740 FF | 100% |  | 28,520 | 28,520 | E3A0750 | E3A0750 | 869 | 12 | 200 | LND | E | B | EB95 | LUZ2 | 3 | LND |  |  |  | E | DC | 200 | A07 | 2DC8640 | 400 |  | C2 |  |  |
| E3A0310 |  | A03 Catalyst Drum Roller - Inquiry Spec. |  | 8d | 2008-08-20 A | 2008-08-29 A | F1670 SS+125d | 100% |  |  |  | E3A0310 | E3A0310 | 869 | 12 | 200 | LND | E | B | EB93 | LUZ2 | 3 | LND |  |  |  | E |  | 200 | A03 | 2DC9630 | 055 | DEV | 0 |  |  |
| E3A0450 |  | A04 R Overhead Separ. - Vendor dwgs approved | milestone | 0d | 2008-09-06 A | 2008-09-06 A | E3A0440 FF | 100% |  | 128,738.4 | 128,738.4 | E3A0450 | E3A0450 | 869 | 12 | 200 | LND | E | B | EB15 | LUZ2 | 3 | LND |  |  |  | E | DC | 200 | A04 | 2DC8500 | 400 |  | C2 |  |  |
| E3A0760 |  | A07 R Fines Eductor - 2nd Review Vendor Dwgs |  | 8d | 2008-09-16 A | 2008-09-25 A | E3A0750, E3A0740 FS+15d | 100% |  |  |  | E3A0760 | E3A0760 | 869 | 12 | 200 | LND | E | B | EB95 | LUZ2 | 3 | LND |  |  |  | E | DC | 200 | A07 | 2DC8640 | 400 |  | C2 |  |  |
| E3A1710 |  | A17 Teal S. C. Internal - Inquiry Spec. |  | 9d | 2008-09-22 A | 2008-10-02 A | F1670 SS | 100% |  |  |  | E3A1710 | E3A1710 | 869 | 12 | 200 | LND | E | B | EB13 | LUZ2 | 3 | LND |  |  |  | E |  | 200 | A17 | 2DD8530 | 055 | DEV | 0 |  |  |
| E3A04A30 |  | A04A R Overhead Cond. - Techn. Eval./Bid Tab Fin | milestone | 0d | 2008-09-23 A | 2008-09-23 A | P3A04AC FF-6d, F5390 | 100% |  |  |  | E3A04A30 | E3A04A30 | 869 | 12 | 200 | LND | E | B | EB14 | LUZ2 | 3 | LND |  |  |  | E | DC | 200 | A04A | 2DC9110 | 400 |  | C2 | 3A |  |
| E3A0460 |  | A04 R Overhead Separ. - 2nd Review Vendor Dwgs |  | 17d | 2008-10-29 A | 2008-11-24 A | P3A04D FS+93d, E3A0450 | 100% |  |  |  | E3A0460 | E3A0460 | 869 | 12 | 200 | LND | E | B | EB15 | LUZ2 | 3 | LND |  |  |  | E | DC | 200 | A04 | 2DC8500 | 400 |  | C2 |  |  |
| E3A0620 |  | A06 Start-Up Heater/Condenser - Techn. Eval./PO Spec |  | 319d | 2008-11-26 A | 2010-03-08 A | P3A06B FS+125d | 100% | TAA [800 h] |  |  | E3A0620 | E3A0620 | 869 | 12 | 200 | LND | E | B | EB24 | LUZ2 | 2 | LND |  |  |  | E |  | 200 | A06 | 2DD8530 | 055 |  | 0 |  | 800,00 |
| E3A0120 |  | A01 Drums/Small Vessels- Techn. Eval./PO Spec |  | 318d | 2008-11-27 A | 2010-03-08 A | P3A01B FS+180d | 100% | TAA [2400 h] |  |  | E3A0120 | E3A0120 | 869 | 12 | 200 | LND | E | B | EB14 | LUZ2 | 2 | LND |  |  |  | E |  | 200 | A01 | 2DD8530 | 055 |  | 0 |  | 2400,00 |
| E3A0560 |  | A05 Offgas Cyclone&R - 2nd Review Vendor Dwgs |  | 10d | 2008-12-01 A | 2008-12-12 A | E3A0550 FS+30d, E3A0540 FS+5d | 100% |  |  |  | E3A0560 | E3A0560 | 869 | 12 | 200 | LND | E | B | EB15 | LUZ2 | 3 | LND |  |  |  | E | DC | 200 | A05 | 2DC8590 | 400 |  | C2 |  |  |
| E3A04A40 |  | A04A R Overhead Cond. - 1st Review Vendor Dwgs |  | 14d | 2009-01-06 A | 2009-01-23 A | P3A04AD FS+50d | 100% |  |  |  | E3A04A40 | E3A04A40 | 869 | 12 | 200 | LND | E | B | EB15 | LUZ2 | 3 | LND |  |  |  | E | DC | 200 | A04A | 2DC9110 | 400 | DFA | C2 | 3A |  |
| E3A04A50 |  | A04A R Overhead Cond. - Vendor dwgs approved | milestone | 0d | 2009-01-24 A | 2009-01-24 A | E3A04A40 FF | 100% |  | 395,400 | 395,400 | E3A04A50 | E3A04A50 | 869 | 12 | 200 | LND | E | B | EB15 | LUZ2 | 3 | LND |  |  |  | E | DC | 200 | A04A | 2DC9110 | 400 |  | C2 |  |  |
| E3A1120 |  | A11 Unloading Arms - Techn. Eval./PO Spec |  | 238d | 2009-02-03 A | 2010-01-14 A | P3A11B FS+45d | 100% | TAA [480 h] |  |  | E3A1120 | E3A1120 | 869 | 12 | 200 | LND | E | B | EB94 | LUZ2 | 3 | LND |  |  |  | E |  | 200 | A11 | 2KB4420 | 055 |  | 0 |  | 480,00 |
| E3A04A60 |  | A04A R Overhead Cond. - 2nd Review Vendor Dwgs |  | 18d | 2009-03-17 A | 2009-04-09 A | E3A04A50, E3A04A40 FS+20d | 100% |  |  |  | E3A04A60 | E3A04A60 | 869 | 12 | 200 | LND | E | B | EB15 | LUZ2 | 3 | LND |  |  |  | E | DC | 200 | A04A | 2DC9110 | 400 |  | C2 |  |  |
| E3A1130 |  | A11 Unloading Arms -Techn. Eval./Bid Tab F | milestone | 0d | 2009-07-03 A | 2009-07-03 A | E3A1115 SF, E3A1120 FF-21d | 100% |  |  |  | E3A1130 | E3A1130 | 869 | 12 | 200 | LND | E | B | EB94 | LUZ2 | 3 | LND |  |  |  | E |  | 200 | A11 | 2KB4420 | 055 |  | 0 |  |  |
| E3A02C10 |  | A02C Instrument Air Vessels - Inquiry Spec. |  | 50d | 2009-10-26 A | 2010-01-08 A | F1670 SS+70d | 100% | TAA [400 h] |  |  | E3A02C10 | E3A02C10 | 869 | 12 | 200 | LND | E | B | EB13 | LUZ2 | 3 | LND |  |  |  | E |  | 200 | A02C | 2DD8530 | 055 | DEV | 0 |  | 400,00 |
| EB000100 |  | Inspections and Acceptance of Equipment w/o Flare and PRU |  | 314d | 2009-12-01 A | 2011-02-28 A | P3U02X SS | 100% | TAA [7600 h] |  |  | EB000100 | EB000100 | 869 | 12 | 200 | LND | E | B | EB15 | LUZ2 | 3 | LND |  |  |  | E |  | 200 | A00B |  | 055 |  | 0 |  | 7600,00 |
| EB1000 |  | General tasks & coordinations DE Phase (TAA) |  | 298d | 2009-12-01 A | 2011-02-04 A | DE1000, EB000100 FF | 100% | TAA [13888 h] |  |  | EB1000 | EB1000 | 869 | 12 | 200 | LND | E | B | EB15 | LUZ2 | 3 | LND |  |  |  | E |  | 200 | A00B |  | 055 |  | 0 |  | 13888,00 |
| E3A0320 |  | A03 Catalyst Drum Roller - Techn. Eval./PO Spec |  | 54d | 2009-12-14 A | 2010-03-03 A | P3A03B FS+340d, HEB20 FF | 100% | TAA [240 h] |  |  | E3A0320 | E3A0320 | 869 | 12 | 200 | LND | E | B | EB94 | LUZ2 | 2 | LND |  |  |  | E |  | 200 | A03 | 2DC9630 | 055 |  | 0 |  | 240,00 |
| E3A1220 |  | A12 Overhead Cranes - Techn. Eval./PO Spec |  | 354d | 2009-12-14 A | 2011-05-06 A | P3A12B FS+60d, P3C02D1 FF | 100% |  |  |  | E3A1220 | E3A1220 | 869 | 12 | 200 | LND | E | B | EB14 | LUZ2 | 3 | LND |  |  |  | E |  | 200 | A12 | 2KB4740 | 055 |  | 0 |  |  |
| E3A1720 |  | A17 Teal S. C. Internal - Techn. Eval./PO Spec (w.Press.Eqpt) |  | 51d | 2009-12-22 A | 2010-03-08 A | P3A17B FS+220d, E3A0120 FF, HEB20 FF | 100% | TAA [400 h] |  |  | E3A1720 | E3A1720 | 869 | 12 | 200 | LND | E | B | EB14 | LUZ2 | 2 | LND |  |  |  | E |  | 200 | A17 | 2DD8530 | 055 |  | 0 |  | 400,00 |
| E3A02C20 |  | A02C Instrument Air Vessels - Techn. Eval./PO Spec |  | 36d | 2010-01-18 A | 2010-03-08 A | P3A02CB FS+10d, HEB20 FF | 100% | TAA [800 h] |  |  | E3A02C20 | E3A02C20 | 869 | 12 | 200 | LND | E | B | EB14 | LUZ2 | 3 | LND |  |  |  | E |  | 200 | A02C | 2DD8530 | 055 |  | 0 |  | 800,00 |
| E3A1730 |  | A17 Teal S. C. Int - Techn. Eval./Bid Tab Final. | milestone | 0d | 2010-02-02 A | 2010-02-02 A | E3A1720 FF-8d | 100% |  |  |  | E3A1730 | E3A1730 | 869 | 12 | 200 | LND | E | B | EB14 | LUZ2 | 2 | LND |  |  |  | E |  | 200 | A17 | 2DD8530 | 055 |  | 0 |  |  |
| E3A0330 |  | A03 Catalyst Drum Roller -Techn. Eval./Bid Tab F | milestone | 0d | 2010-02-05 A | 2010-02-05 A | E3A0320 FF-11d, E3A0315 SF | 100% |  |  |  | E3A0330 | E3A0330 | 869 | 12 | 200 | LND | E | B | EB94 | LUZ2 | 2 | LND |  |  |  | E |  | 200 | A03 | 2DC9630 | 055 |  | 0 |  |  |
| E3A1140 |  | A11 Unloading Arms - 1st Review dwgs |  | 15d | 2010-02-22 A | 2010-03-12 A | P3A11L SS+40d | 100% | TAA [800 h] |  |  | E3A1140 | E3A1140 | 869 | 12 | 200 | LND | E | B | EB95 | LUZ2 | 3 | LND |  |  |  | E |  | 200 | A11 | 2KB4420 | 055 |  | 0 |  | 800,00 |
| E3A0130 |  | A01 Drums/Small V. - Techn. Eval./Bid Tab Final. | milestone | 0d | 2010-02-25 A | 2010-02-25 A | E3A0120 FF-8d, E3A0115 SF | 100% |  |  |  | E3A0130 | E3A0130 | 869 | 12 | 200 | LND | E | B | EB14 | LUZ2 | 2 | LND |  |  |  | E |  | 200 | A01 | 2DD8530 | 055 |  | 0 |  |  |
| E3A02C30 |  | A02C Instrument Air Vessels - Techn. Eval./Bid Tab F | milestone | 0d | 2010-02-25 A | 2010-02-25 A | E3A02C20 FF-8d | 100% |  |  |  | E3A02C30 | E3A02C30 | 869 | 12 | 200 | LND | E | B | EB14 | LUZ2 | 3 | LND |  |  |  | E |  | 200 | A02C | 2DD8530 | 055 |  | 0 |  |  |
| E3A1150 |  | A11 Unloading Arms - Vendor dwgs approved | milestone | 0d | 2010-03-12 A | 2010-03-12 A | E3A1140 FF | 100% |  | 28,808 | 28,808 | E3A1150 | E3A1150 | 869 | 12 | 200 | LND | E | B | EB95 | LUZ2 | 3 | LND |  |  |  | E |  | 200 | A11 | 2KB4420 | 055 | DFA | 0 |  |  |
| E3A0340 |  | A03 Catalyst Drum Roller - 1st Review dwgs |  | 8d | 2010-03-29 A | 2010-04-09 A | HEB50 FF, P3A03L SS+25d | 100% | TAA [240 h] |  |  | E3A0340 | E3A0340 | 869 | 12 | 200 | LND | E | B | EB95 | LUZ2 | 3 | LND |  |  |  | E |  | 200 | A03 | 2DC9630 | 055 |  | 0 |  | 240,00 |
| E3A0350 |  | A03 Catalyst Drum Roller - Vendor dwgs approved | milestone | 0d | 2010-04-09 A | 2010-04-09 A | E3A0340 FF | 100% |  | 13,460 | 13,460 | E3A0350 | E3A0350 | 869 | 12 | 200 | LND | E | B | EB95 | LUZ2 | 3 | LND |  |  |  | E |  | 200 | A03 | 2DC9630 | 055 | DFA | 0 |  |  |
| E3A0140 |  | A01 Drums/Small Vessel - 1st Review Vendor dwgs |  | 20d | 2010-04-23 A | 2010-05-21 A | P3A01L SS+45d | 100% | TAA [2400 h] |  |  | E3A0140 | E3A0140 | 869 | 12 | 200 | LND | E | B | EB15 | LUZ2 | 3 | LND |  |  |  | E |  | 200 | A01 | 2DD8530 | 055 |  | 0 |  | 2400,00 |
| E3A02C40 |  | A02C Instrument Air Vessels - 1st Review dwgs |  | 20d | 2010-04-23 A | 2010-05-21 A | HEB50 FF, P3A02CL SS+45d | 100% | TAA [400 h] |  |  | E3A02C40 | E3A02C40 | 869 | 12 | 200 | LND | E | B | EB15 | LUZ2 | 3 | LND |  |  |  | E |  | 200 | A02C | 2DD8530 | 055 |  | 0 |  | 400,00 |
| E3A0640 |  | A06 Start-Up Heater/Condenser - 1st Review dwgs |  | 18d | 2010-04-23 A | 2010-05-19 A | P3A06L SS+45d | 100% | TAA [1600 h] |  |  | E3A0640 | E3A0640 | 869 | 12 | 200 | LND | E | B | EB25 | LUZ2 | 3 | LND |  |  |  | E |  | 200 | A06 | 2DD8530 | 055 |  | 0 |  | 1600,00 |

Notes:
- E3A0550: Expenses: 900A 71648.8
- E3A0750: Expenses: 900A 28520
- E3A0450: Expenses: 900A 128738
- E3A04A50: Expenses: 900A 395400
- E3A1150: Expenses: 900A 28808
- E3A0350: Expenses: 900A 13460

| ID | WBS | Activity | Type | Duration | Start | Finish | Predecessors | Complete | Resources | Cost | Actual cost | TB26 Ressource Budget | UDF_SAVE ACTID | UDF_SAVE ACT ID | Department | Type of Work | Constr. Area | Inquiry/Order No | PMT-Area | PMT-Schedule Org | PMT-Discipline | PMT-Phase | PMT-Respons. | Zeigen/n. Zeigen | WBS Phase | WBS Discipline | WBS Type of Work | WBS Objects | IMS | UPT | PMT-Doc. Type | Pro Unit/DocCode | PMT-Stage |
| --- | --- | --- | --- | --- | --- | --- | --- | --- | --- | --- | --- | --- | --- | --- | --- | --- | --- | --- | --- | --- | --- | --- | --- | --- | --- | --- | --- | --- | --- | --- | --- | --- | --- |
| E3A1740 |  | A17 Teal S. C. Interna - 1st Review Vendor dwgs |  | 20d | 2010-04-23 A | 2010-05-21 A | HEB50 FF, P3A17L SS+45d | 100% | TAA [400 h] |  |  | 400,00 | E3A1740 | E3A1740 | 869 | A17 | 12 | 2DD8530 | 200 | 200 | 055 | E | LND | 0 | E | B | EB15 | LUZ2 | 3 | LND |  |  |  |
| E3A0360 |  | A03 Catalyst Drum Roller - 2nd Review dwgs |  | 40d | 2010-04-26 A | 2010-06-22 A | E3A0350, P3A03L SS+65d | 100% | TAA [240 h] |  |  | 240,00 | E3A0360 | E3A0360 | 869 | A03 | 12 | 2DC9630 | 200 | 200 | 055 | E | LND | 0 | E | B | EB95 | LUZ2 | 3 | LND |  |  |  |
| E3A0650 |  | A06 Start-Up Heater/Condenser - Vendor dwgs approved | milestone | 0d | 2010-05-19 A | 2010-05-19 A | E3A0640 FF | 100% |  | 37,280 | 37,280 |  | E3A0650 | E3A0650 | 869 | A06 | 12 | 2DD8530 | 200 | 200 | 055 | E | LND | 0 | E | B | EB25 | LUZ2 | 3 | LND | DFA |  |  |
| E3A0150 |  | A01 Drums/Small Vessels - Vendor dwgs approved | milestone | 0d | 2010-05-21 A | 2010-05-21 A | E3A0140 FF | 100% |  | 82,032 | 82,032 |  | E3A0150 | E3A0150 | 869 | A01 | 12 | 2DD8530 | 200 | 200 | 055 | E | LND | 0 | E | B | EB15 | LUZ2 | 3 | LND | DFA |  |  |
| E3A02C50 |  | A02C Instrument Air Vessels - Vendor dwgs approved | milestone | 0d | 2010-05-21 A | 2010-05-21 A | E3A02C40 FF | 100% |  | 24,800 | 24,800 |  | E3A02C50 | E3A02C50 | 869 | A02C | 12 | 2DD8530 | 200 | 200 | 055 | E | LND | 0 | E | B | EB15 | LUZ2 | 3 | LND | DFA |  |  |
| E3A1750 |  | A17 Teal S. C. Internal - Vendor dwgs approved | milestone | 0d | 2010-05-21 A | 2010-05-21 A | E3A1740 FF | 100% |  |  |  |  | E3A1750 | E3A1750 | 869 | A17 | 12 | 2DD8530 | 200 | 200 | 055 | E | LND | 0 | E | B | EB15 | LUZ2 | 3 | LND | DFA |  |  |
| E3A1160 |  | A11 Unloading Arms - 2nd Review dwgs |  | 34d | 2010-05-25 A | 2010-07-09 A | E3A1150, E3A1140 SS+55d | 100% | TAA [400 h] |  |  | 400,00 | E3A1160 | E3A1160 | 869 | A11 | 12 | 2KB4420 | 200 | 200 | 055 | E | LND | 0 | E | B | EB95 | LUZ2 | 3 | LND |  |  |  |
| E3A0160 |  | A01 Drums/Small Vessel - 2nd Review Vendor dwgs |  | 28d | 2010-06-28 A | 2010-08-04 A | P3A01L SS+113d, E3A0150 | 100% | TAA [1600 h] |  |  | 1600,00 | E3A0160 | E3A0160 | 869 | A01 | 12 | 2DD8530 | 200 | 200 | 055 | E | LND | 0 | E | B | EB15 | LUZ2 | 3 | LND |  |  |  |
| E3A02C60 |  | A02C Instrument Air Vessels - 2nd Review dwgs |  | 28d | 2010-06-28 A | 2010-08-04 A | E3A02C50 FS+10d, P3A02CL SS+90d | 100% | TAA [400 h] |  |  | 400,00 | E3A02C60 | E3A02C60 | 869 | A02C | 12 | 2DD8530 | 200 | 200 | 055 | E | LND | 0 | E | B | EB15 | LUZ2 | 3 | LND |  |  |  |
| E3A0570 |  | A05 Offgas Cyclone&R - Review Final Documentation |  | 74d | 2010-06-28 A | 2010-10-07 A | E3A0560, P3A05L FS+50d | 100% | TAA [800 h] |  |  | 800,00 | E3A0570 | E3A0570 | 869 | A05 | 12 | 2DC8590 | 200 | 200 | 400 | E | LND | C2 | E | B | EB15 | LUZ2 | 3 | LND |  | DC |  |
| E3A0660 |  | A06 Start-Up Heater/Condenser - 2nd Review dwgs |  | 35d | 2010-06-28 A | 2010-08-13 A | E3A0650, P3A06L SS+85d | 100% | TAA [1600 h] |  |  | 1600,00 | E3A0660 | E3A0660 | 869 | A06 | 12 | 2DD8530 | 200 | 200 | 055 | E | LND | 0 | E | B | EB25 | LUZ2 | 3 | LND |  |  |  |
| E3A1760 |  | A17 Teal S. C. Interna - 2nd Review Vendor dwgs |  | 25d | 2010-07-01 A | 2010-08-04 A | P3A17L SS+85d, E3A1750 FS+27d | 100% |  |  |  |  | E3A1760 | E3A1760 | 869 | A17 | 12 | 2DD8530 | 200 | 200 | 055 | E | LND | 0 | E | B | EB15 | LUZ2 | 3 | LND |  |  |  |
| E3A1230 |  | A12 Overhead Cranes -Techn. Eval./Bid Tab F | milestone | 0d | 2010-10-29 A | 2010-10-29 A | E3A1220 FF-21d | 100% |  |  |  |  | E3A1230 | E3A1230 | 869 | A12 | 12 | 2KB4740 | 200 | 200 | 055 | E | LND | 0 | E | B | EB94 | LUZ2 | 3 | LND |  |  |  |
| E3A04A70 |  | A04A R Overhead Cond. - Review Final Documentation |  | 20d | 2010-12-09 A | 2011-01-07 A | P3A04AL FF+60d, E3A0460 | 100% | TAA |  |  | 0,00 | E3A04A70 | E3A04A70 | 869 | A04A | 12 | 2DC9110 | 200 | 200 | 400 | E | LND | C2 | E | B | EB15 | LUZ2 | 3 | LND |  | DC |  |
|  | M | **M Mechanical - Rotating Equipment** |  |  | 2008-02-18 | 2010-10-14 |  |  |  |  |  |  |  |  |  |  |  |  |  |  |  |  |  |  |  |  |  |  |  |  |  |  |  |
| E3M0810 |  | M08 Teal/Donor Feed Pumps - Inquiry Spec. |  | 10d | 2008-02-18 A | 2008-02-29 A | F1670 SS+30d | 100% |  |  |  |  | E3M0810 | E3M0810 | 867 | M08 | 12 | 2PA6690 | 200 | 200 | 055 | E | LND | 1 | E | M | EM23 | LUZ2 | I | LND | DEV |  |  |
| E3M0710 |  | M07 Catalyst Feed Pumps - Inquiry Spec. |  | 14d | 2008-04-28 A | 2008-05-19 A | F1670 SS+30d | 100% |  |  |  |  | E3M0710 | E3M0710 | 867 | M07 | 12 | 2PA6670 | 200 | 200 | 055 | E | LND | 0 | E | M | EM23 | LUZ2 | I | LND | DEV |  |  |
| E3M1010 |  | M10 Catalyst Waste Pumps - Inquiry Spec. |  | 9d | 2008-05-09 A | 2008-05-22 A | F1670 SS+55d | 100% |  |  |  |  | E3M1010 | E3M1010 | 867 | M10 | 12 | 2PA6690 | 200 | 200 | 055 | E | LND | 1 | E | M | EM23 | LUZ2 | 3 | LND | DEV |  |  |
| E3M1120 |  | M11 RA Gear Unit - Techn. Eval./PO Spec. |  | 92d | 2008-05-22 A | 2008-09-26 A | P3M11C FF | 100% |  |  |  |  | E3M1120 | E3M1120 | 867 | M11 | 12 | 2KB4290 | 200 | 200 | 400 | E | LND | C2 | E | M | EM94 | LUZ2 | 3 | LND |  | DC | 3A |
| E3M0520 |  | M05 R. Quench Pumps - Techn. Eval./PO Spec. |  | 105d | 2008-05-23 A | 2008-10-17 A | P3M05C FF | 100% |  |  |  |  | E3M0520 | E3M0520 | 867 | M05 | 12 | 2PA6550 | 200 | 200 | 400 | E | LND | C2 | E | M | EM24 | LUZ2 | I | LND |  | DC |  |
| E3M0620 |  | M06 R. Tepid Pumps - Techn. Eval./PO Spec. |  | 56d | 2008-05-23 A | 2008-08-08 A | P3M06C FF | 100% |  |  |  |  | E3M0620 | E3M0620 | 867 | M06 | 12 | 2PA6540 | 200 | 200 | 400 | E | LND | C2 | E | M | EM24 | LUZ2 | I | LND |  | DC |  |
| E3M0910 |  | M09 Unloading Pumps - Inquiry Spec. |  | 9d | 2008-05-26 A | 2008-06-05 A | F1670 SS+65d | 100% |  |  |  |  | E3M0910 | E3M0910 | 867 | M09 | 12 | 2PA6680 | 200 | 200 | 055 | E | LND | 1 | E | M | EM23 | LUZ2 | 3 | LND | DEV |  |  |
| E3M0820 |  | M08 Teal/Donor Feed Pumps - Techn. Eval./PO Spec |  | 83d | 2008-07-21 A | 2008-11-14 A | P3M08B FS+60d | 100% |  |  |  |  | E3M0820 | E3M0820 | 867 | M08 | 12 | 2PA6690 | 200 | 200 | 055 | E | LND | 1 | E | M | EM24 | LUZ2 | I | LND |  |  |  |
| E3M1020 |  | M10 Catalyst Waste Pumps - Techn. Eval./PO Spec |  | 83d | 2008-07-21 A | 2008-11-14 A | P3M10B FS+37d | 100% |  |  |  |  | E3M1020 | E3M1020 | 867 | M10 | 12 | 2PA6690 | 200 | 200 | 055 | E | LND | 1 | E | M | EM24 | LUZ2 | 3 | LND |  |  |  |
| E3M0530 |  | M05 R. Quench Pumps -Techn. Eval./Bid Tab F | milestone | 0d | 2008-07-24 A | 2008-07-24 A | P3M05C FF-10d, F7730 | 100% |  |  |  |  | E3M0530 | E3M0530 | 867 | M05 | 12 | 2PA6550 | 200 | 200 | 055 | E | LND | C2 | E | M | EM24 | LUZ2 | I | LND |  |  |  |
| E3M0630 |  | M06 R. Tepid Pumps -Techn. Eval./Bid Tab Fin | milestone | 0d | 2008-07-24 A | 2008-07-24 A | F7430, P3M06C FF-5d | 100% |  |  |  |  | E3M0630 | E3M0630 | 867 | M06 | 12 | 2PA6540 | 200 | 200 | 055 | E | LND | C2 | E | M | EM24 | LUZ2 | I | LND |  |  |  |
| E3M1130 |  | M11 RA Gear Unit - Techn. Eval./Bid Tab Finalize | milestone | 0d | 2008-08-09 A | 2008-08-09 A | F6890, E3M1120 FF-5d | 100% |  |  |  |  | E3M1130 | E3M1130 | 867 | M11 | 12 | 2KB4290 | 200 | 200 | 055 | E | LND | C2 | E | M | EM94 | LUZ2 | 3 | LND |  |  |  |
| E3M0720 |  | M07 Catalyst Feed Pumps - Techn. Eval./PO Spec |  | 53d | 2008-08-20 A | 2008-11-04 A | P3M07B FS+60d | 100% |  |  |  |  | E3M0720 | E3M0720 | 867 | M07 | 12 | 2PA6670 | 200 | 200 | 055 | E | LND | 0 | E | M | EM24 | LUZ2 | I | LND |  |  |  |
| E3M0640 |  | M06 R. Tepid Pumps - 1st Review Vendor Dwgs |  | 10d | 2008-08-27 A | 2008-09-09 A | P3M06D1 FS+25d | 100% |  |  |  |  | E3M0640 | E3M0640 | 867 | M06 | 12 | 2PA6540 | 200 | 200 | 400 | E | LND | C2 | E | M | EM25 | LUZ2 | I | LND | DFA | DC |  |
| E3M0730 |  | M07 Catalyst Feed Pumps -Techn. Eval./Bid Tab F | milestone | 0d | 2008-09-27 A | 2008-09-27 A | E3M0720 FF-6d, E3M0715 SF | 100% |  |  |  |  | E3M0730 | E3M0730 | 867 | M07 | 12 | 2PA6670 | 200 | 200 | 055 | E | LND | 0 | E | M | EM24 | LUZ2 | I | LND |  |  |  |
| E3M0650 |  | M06 R. Tepid Pumps - Vendor dwgs approved | milestone | 0d | 2008-10-01 A | 2008-10-01 A | E3M0640 FF | 100% |  | 37,796 | 37,796 |  | E3M0650 | E3M0650 | 867 | M06 | 12 | 2PA6540 | 200 | 200 | 400 | E | LND | C2 | E | M | EM25 | LUZ2 | I | LND |  | DC |  |
| E3M0830 |  | M08 Teal/Donor Feed Pump -Techn. Eval./Bid Tab F | milestone | 0d | 2008-10-22 A | 2008-10-22 A | E3M0815 SF, E3M0820 FF-5d | 100% |  |  |  |  | E3M0830 | E3M0830 | 867 | M08 | 12 | 2PA6690 | 200 | 200 | 055 | E | LND | 1 | E | M | EM24 | LUZ2 | I | LND |  |  |  |
| E3M1030 |  | M10 Catalyst Waste Pumps- Techn. Eval./Bid Tab F | milestone | 0d | 2008-10-22 A | 2008-10-22 A | E3M1015 SF, E3M1020 FF-5d | 100% |  |  |  |  | E3M1030 | E3M1030 | 867 | M10 | 12 | 2PA6690 | 200 | 200 | 055 | E | LND | 1 | E | M | EM24 | LUZ2 | 3 | LND |  |  |  |
| E3M0920 |  | M09 Unloading Pumps - Techn. Eval./PO Spec |  | 431d | 2008-11-03 A | 2010-07-26 A | P3M09B FS+120d | 100% | TAM [400 h] |  |  | 400,00 | E3M0920 | E3M0920 | 867 | M09 | 12 | 2PA6680 | 200 | 200 | 055 | E | LND | 1 | E | M | EM24 | LUZ2 | 2 | LND |  |  |  |
| E3M1140 |  | M11 RA Gear Unit - 1st Review Vendor Dwgs |  | 15d | 2008-11-24 A | 2008-12-12 A | P3M11D FS+20d | 100% |  |  |  |  | E3M1140 | E3M1140 | 867 | M11 | 12 | 2KB4290 | 200 | 200 | 400 | E | LND | C2 | E | M | EM95 | LUZ2 | 3 | LND | DFA | DC | 3A |
| E3M0930 |  | M09 Unloading Pumps - Techn. Eval./Bid Tab F | milestone | 0d | 2008-11-28 A | 2008-11-28 A | E3M0920 FF-8d, E3M0915 SF | 100% |  |  |  |  | E3M0930 | E3M0930 | 867 | M09 | 12 | 2PA6680 | 200 | 200 | 055 | E | LND | 1 | E | M | EM24 | LUZ2 | 2 | LND |  |  |  |
| E3M0740 |  | M07 Catalyst Feed Pumps - 1st Review dwgs |  | 11d | 2008-12-05 A | 2008-12-19 A | P3M07L SS+30d | 100% |  |  |  |  | E3M0740 | E3M0740 | 867 | M07 | 12 | 2PA6670 | 200 | 200 | 055 | E | LND | 0 | E | M | EM25 | LUZ2 | I | LND |  |  |  |
| E3M0540 |  | M05 R. Quench Pumps - 1st Review Vendor Dwgs |  | 10d | 2008-12-08 A | 2008-12-19 A | P3M05D FS+20d | 100% |  |  |  |  | E3M0540 | E3M0540 | 867 | M05 | 12 | 2PA6550 | 200 | 200 | 400 | E | LND | C2 | E | M | EM25 | LUZ2 | I | LND | DFA | DC |  |
| E3M0660 |  | M06 R. Tepid Pumps - 2nd Review Vendor Dwgs |  | 10d | 2008-12-08 A | 2008-12-19 A | E3M0650, E3M0640 FS+20d | 100% |  |  |  |  | E3M0660 | E3M0660 | 867 | M06 | 12 | 2PA6540 | 200 | 200 | 400 | E | LND | C2 | E | M | EM25 | LUZ2 | I | LND |  | DC |  |
| E3M1150 |  | M11 RA Gear Unit - Vendor dwgs approved | milestone | 0d | 2008-12-13 A | 2008-12-13 A | E3M1140 FF | 100% |  | 228,180 | 228,180 |  | E3M1150 | E3M1150 | 867 | M11 | 12 | 2KB4290 | 200 | 200 | 400 | E | LND | C2 | E | M | EM95 | LUZ2 | 3 | LND |  | DC |  |
| E3M0750 |  | M07 Catalyst Feed Pumps - Vendor dwgs approved | milestone | 0d | 2008-12-20 A | 2008-12-20 A | E3M0740 FF | 100% |  | 34,950.6 | 34,950.6 |  | E3M0750 | E3M0750 | 867 | M07 | 12 | 2PA6670 | 200 | 200 | 055 | E | LND | 0 | E | M | EM25 | LUZ2 | I | LND | DFA |  |  |
| E3M0550 |  | M05 R. Quench Pumps - Vendor dwgs. approved(AFM) | milestone | 0d | 2008-12-23 A | 2008-12-23 A | E3M0540 FF | 100% |  | 232,358.8 | 232,358.8 |  | E3M0550 | E3M0550 | 867 | M05 | 12 | 2PA6550 | 200 | 200 | 400 | E | LND | C2 | E | M | EM25 | LUZ2 | I | LND |  | DC |  |
| E3M1160 |  | M11 RA Gear Unit - 2nd Review Vendor Dwgs |  | 15d | 2009-01-12 A | 2009-01-30 A | E3M1150, E3M1140 FS+15d | 100% |  |  |  |  | E3M1160 | E3M1160 | 867 | M11 | 12 | 2KB4290 | 200 | 200 | 400 | E | LND | C2 | E | M | EM95 | LUZ2 | 3 | LND |  | DC |  |
| E3M0760 |  | M07 Catalyst Feed Pumps - 2nd Review dwgs |  | 10d | 2009-01-19 A | 2009-01-30 A | P3M07L SS+70d | 100% |  |  |  |  | E3M0760 | E3M0760 | 867 | M07 | 12 | 2PA6670 | 200 | 200 | 055 | E | LND | 0 | E | M | EM25 | LUZ2 | I | LND |  |  |  |
| E3M0560 |  | M05 R. Quench Pumps - 2nd Review Vendor Dwgs |  | 15d | 2009-02-02 A | 2009-02-20 A | E3M0550, E3M0540 FS+20d | 100% |  |  |  |  | E3M0560 | E3M0560 | 867 | M05 | 12 | 2PA6550 | 200 | 200 | 400 | E | LND | C2 | E | M | EM25 | LUZ2 | I | LND |  | DC |  |
| E3M0840 |  | M08 Teal/Donor Feed Pumps - 1st Review dwgs |  | 10d | 2009-10-20 A | 2009-11-02 A | HEB50 FF, P3M08D1 SS+34d | 100% | TAM [192 h] |  |  | 192,00 | E3M0840 | E3M0840 | 867 | M08 | 12 | 2PA6690 | 200 | 200 | 055 | E | LND | 1 | E | M | EM25 | LUZ2 | I | LND |  |  |  |
| E3M1040 |  | M10 Catalyst Waste Pumps - 1st Review dwgs |  | 10d | 2009-10-20 A | 2009-11-02 A | HEB50 FF, P3M10D1 FS+34d | 100% | TAM [160 h] |  |  | 160,00 | E3M1040 | E3M1040 | 867 | M10 | 12 | 2PA6690 | 200 | 200 | 055 | E | LND | 1 | E | M | EM25 | LUZ2 | 3 | LND |  |  |  |
| E3M0850 |  | M08 Teal/Donor Feed Pump - Vendor dwgs approved | milestone | 0d | 2009-11-02 A | 2009-11-02 A | E3M0840 FF | 100% |  | 20,590.6 | 20,590.6 |  | E3M0850 | E3M0850 | 867 | M08 | 12 | 2PA6690 | 200 | 200 | 055 | E | LND | 1 | E | M | EM25 | LUZ2 | I | LND | DFA |  |  |
| E3M1050 |  | M10 Catalyst Waste Pumps - Vendor dwgs approved | milestone | 0d | 2009-11-02 A | 2009-11-02 A | E3M1040 FF | 100% |  | 10,819.6 | 10,819.6 |  | E3M1050 | E3M1050 | 867 | M10 | 12 | 2PA6690 | 200 | 200 | 055 | E | LND | 1 | E | M | EM25 | LUZ2 | 3 | LND | DFA |  |  |
| E3M1165 |  | M11 RA Gear Unit - 2nd Review Rejustment Vendor Dwgs |  | 80d | 2009-12-07 A | 2010-04-01 A | E3M1160 | 100% | TAM [800 h] |  |  | 800,00 | E3M1165 | E3M1165 | 867 | M11 | 12 | 2KB4290 | 200 | 200 | 400 | E | LND | C2 | E | M | EM95 | LUZ2 | 3 | LND |  | DC |  |
| E3M0860 |  | M08 Teal/Donor Feed Pumps - 2nd Review dwgs |  | 54d | 2009-12-16 A | 2010-03-05 A | E3M0850 SS+30d | 100% | TAM [480 h] |  |  | 480,00 | E3M0860 | E3M0860 | 867 | M08 | 12 | 2PA6690 | 200 | 200 | 055 | E | LND | 1 | E | M | EM25 | LUZ2 | 3 | LND |  |  |  |
| E3M1060 |  | M10 Catalyst Waste Pumps - 2nd Review dwgs |  | 115d | 2009-12-16 A | 2010-06-04 A | E3M1050 SS+30d | 100% | TAM [240 h] |  |  | 240,00 | E3M1060 | E3M1060 | 867 | M10 | 12 | 2PA6690 | 200 | 200 | 055 | E | LND | 1 | E | M | EM25 | LUZ2 | 3 | LND |  |  |  |
| E3M0940 |  | M09 Unloading Pumps - 1st Review dwgs |  | 5d | 2010-10-04 A | 2010-10-08 A | P3M09L FF | 100% | TAM [192 h] |  |  | 192,00 | E3M0940 | E3M0940 | 867 | M09 | 12 | 2PA6680 | 200 | 200 | 055 | E | LND | 1 | E | M | EM25 | LUZ2 | 3 | LND |  |  |  |
| E3M0950 |  | M09 Unloading Pumps - Vendor dwgs approved | milestone | 0d | 2010-10-08 A | 2010-10-08 A | E3M0940 FF-10d | 100% |  | 6,000 | 6,000 |  | E3M0950 | E3M0950 | 867 | M09 | 12 | 2PA6680 | 200 | 200 | 055 | E | LND | 1 | E | M | EM25 | LUZ2 | 3 | LND | DFA |  |  |
| E3M0960 |  | M09 Unloading Pumps - 2nd Review dwgs |  | 4d | 2010-10-11 A | 2010-10-14 A | P3M09L FF | 100% | TAM [400 h] |  |  | 400,00 | E3M0960 | E3M0960 | 867 | M09 | 12 | 2PA6680 | 200 | 200 | 055 | E | LND | 1 | E | M | EM25 | LUZ2 | 3 | LND |  |  |  |

Notes:
- E3A0650: Expenses: 900A 37280
- E3A0150: Expenses: 900A 82032
- E3A02C50: Expenses: 900A 24800
- E3A1750: Expenses: 900A 0
- E3M0650: Expenses: 900A 37796
- E3M0920: P3 Activity Log Info: on hold by / client
- E3M1150: Expenses: 900A 228180
- E3M0750: Expenses: 900A 34950.6
- E3M0550: Expenses: 900A 232359
- E3M0850: Expenses: 900A 20590.6
- E3M1050: Expenses: 900A 10819.6
- E3M0950: Expenses: 900A 6000

| ID | WBS | Activity | Type | Duration | Start | Finish | Predecessors | Complete | Calendar | Resources | UDF_SAVE ACTID | UDF_SAVE ACT ID | Department | Constr. Area | Pro Unit/DocCode | PMT-Area | PMT-Phase | PMT-Respons. | WBS Phase | WBS Discipline | WBS Type of Work | WBS Objects | IMS | UPT | TB26 Ressource Budget | Inquiry/Order No | Zeigen/n. Zeigen | PMT-Schedule Org | Type of Work | PMT-Discipline |
| --- | --- | --- | --- | --- | --- | --- | --- | --- | --- | --- | --- | --- | --- | --- | --- | --- | --- | --- | --- | --- | --- | --- | --- | --- | --- | --- | --- | --- | --- | --- |
|  | 1200 | **1200 Generals - CA12** |  |  | 2009-11-24 | 2011-03-25 |  |  |  |  |  |  |  |  |  |  |  |  |  |  |  |  |  |  |  |  |  |  |  |  |
|  | C | **C Civil** |  |  | 2009-11-24 | 2011-03-25 |  |  |  |  |  |  |  |  |  |  |  |  |  |  |  |  |  |  |  |  |  |  |  |  |
| EC441200 |  | CA12 General - Civil Layout drwgs / Loads IFD | level of effort | 39d | 2009-11-24 A | 2010-01-21 A | EC221204 FF, EC221201 SS, EC441221 FF, EC441222 SS, EC441221 SS | 100% |  |  | EC441200 | EC441200 | 87A | 12 | 1200C01 | 200 | E | LND | E | C | EC44 | 1200 | de | LND |  |  |  |  |  |  |
| EC071205 |  | CA12 General - Issue of working drwgs (AFC) by RDI |  | 318d | 2009-12-22 A | 2011-03-25 A | EC261201 SS, EC45120110 FF, EC45122110 FF, EC601200 FF, EC45120510 FF, EC45122210 FF, EC45120410 FF | 100% |  | TKB-B [16080 h] | EC071205 | EC071205 | 87A | 12 | 1010C13 | 200 | E | IPR | E | C | EC07 | 1200 | cq | LND | 16080,00 | 999 | FL |  |  |  |
| EC071200 |  | CA12 General - Check & Release of working drwgs (AFC) |  | 289d | 2010-01-11 A | 2011-02-28 A | EC071205 SS+20d | 100% |  | TKB-B [2728 h] | EC071200 | EC071200 | 87A | 12 |  | 200 | E | LND | E | C | EC07 | 1200 | cq | LND | 2728,00 | 999 | FL |  |  |  |
| EC44120005 |  | CA12 General - General Drwgs & Documents |  | 119d | 2010-02-18 A | 2010-08-09 A | EC45120105 FF, EC28120112 FF+5d, EC28120110 FF+5d | 100% |  |  | EC44120005 | EC44120005 | 87A | 12 | 1200C11 | 200 | E | IPR | E | C | EC00 | 1200 | de | LND |  |  |  |  |  |  |
| EC601200 |  | CA12 General - Paving drwgs AFC -heated- |  | 202d | 2010-06-14 A | 2011-03-25 A | EC151200 SS+20d, EC44120005 FF | 100% |  |  | EC601200 | EC601200 | 87A | 12 | 9612C96 | 200 | E | IPR | E | C | EC60 | 1200 | de | LND |  |  |  | 200 |  |  |
|  | R | **R Piping** |  |  | 2010-10-11 | 2010-11-05 |  |  |  |  |  |  |  |  |  |  |  |  |  |  |  |  |  |  |  |  |  |  |  |  |
| ER441200 |  | CA12 General - Piping Isometrics (UG) |  | 20d | 2010-10-11 A | 2010-11-05 A | ER440000 FF, HER44 FF, EC151200 SS+20d | 100% |  |  | ER441200 | ER441200 | 876 | 12 |  | 200 | E | LND | E | R | ER44 | 1200 | 4 | LND |  |  |  | 200 |  |  |
|  | E | **E Electrical** |  |  | 2010-01-26 | 2010-06-30 |  |  |  |  |  |  |  |  |  |  |  |  |  |  |  |  |  |  |  |  |  |  |  |  |
| EE761200 |  | CA12 General - Layout Plan Light.& Sockets 1st Issue |  | 108d | 2010-01-26 A | 2010-06-30 A | EE000180 FS+10d | 100% |  | TAE [3904 h] | EE761200 | EE761200 | 874 | 12 |  |  | E | LEI | E | E | EE76 | 1200 | E | LND | 3904,00 |  |  |  |  |  |
|  | 1201 | **1201 Reactor Structure - CA12** |  |  | 2008-01-25 | 2011-02-04 |  |  |  |  |  |  |  |  |  |  |  |  |  |  |  |  |  |  |  |  |  |  |  |  |
|  | C | **C Civil** |  |  | 2009-11-24 | 2010-09-02 |  |  |  |  |  |  |  |  |  |  |  |  |  |  |  |  |  |  |  |  |  |  |  |  |
| EC221201 |  | CA12 ReactorStruc - Layout Drwg / Loads IFD |  | 20d | 2009-11-24 A | 2009-12-21 A | EM051201, EB051201, EN251201 FF | 100% |  |  | EC221201 | EC221201 | 87A | 12 | 1201C01 | 200 | E | LND | E | C | EC22 | 1201 | de | LND |  |  |  | 200 |  |  |
| EC261201 |  | CA12 ReactorStruc - Civil Static Calc Base+Stru |  | 175d | 2009-12-22 A | 2010-09-02 A | P3C0BD FS+5d, EC221201 | 100% |  |  | EC261201 | EC261201 | 87A | 12 | 1201C14 | 200 |  | IPR | E | C | EC26 | 1201 | de | LND |  |  |  |  |  |  |
| EC45120105 |  | CA12 ReactorStruc - Civil Layout drwgs AFC |  | 126d | 2009-12-22 A | 2010-06-25 A | EC261201 SS, EC221201, AD2230, P3C0BD FS+5d | 100% |  |  | EC45120105 | EC45120105 | 87A | 12 | 1201C13 | 200 | E | IPR | E | C | EC45 | 1201 | ar | LND |  |  |  |  |  |  |
| EC151201 |  | CA12 ReactorStruc - Piling drwgs AFC |  | 45d | 2010-01-11 A | 2010-03-12 A | EC261201 SS+10d | 100% |  |  | EC151201 | EC151201 | 87A | 12 | 1201C16 | 200 |  | IPR | E | C | EC15 | 1201 | PI | LND |  |  |  |  |  |  |
| EC28120105 |  | CA12 ReactorStruc - Formw/Reinf drwgs Baseplate AFC |  | 88d | 2010-01-25 A | 2010-06-01 A | EC151201 SS+10d, EC261201 SS+20d | 100% |  |  | EC28120105 | EC28120105 | 87A | 12 | 1201C21 | 200 | E | IPR | E | C | EC28 | 1201 | cq | LND |  |  |  | 200 |  |  |
| EC28120110 |  | CA12 ReactorStruc - Formw/Reinf drwgs Struc +6m AFC - Columns |  | 107d | 2010-02-19 A | 2010-07-23 A | EC28120105 SS+14d | 100% |  |  | EC28120110 | EC28120110 | 87A | 12 | 1201C32 | 200 | E | IPR | E | C | EC28 | 1201 | ar | LND |  |  |  | 200 |  |  |
| EC28120112 |  | CA12 ReactorStruc - Formw/Reinf drwgs Struc +6m AFC - Beams |  | 127d | 2010-02-19 A | 2010-08-20 A | EC28120105 SS+14d | 100% |  |  | EC28120112 | EC28120112 | 87A | 12 | 1201C32 | 200 | E | IPR | E | C | EC28 | 1201 | ar | LND |  |  |  | 200 |  |  |
| EC45120110 |  | CA12 ReactorStruc - Civil Layout drwgs IFC | milestone | 0d | 2010-05-21 A | 2010-05-21 A | EC45120105 FF-14d | 100% |  |  | EC45120110 | EC45120110 | 87A | 12 |  | 200 | E | IPR | E | C | EC45 | 1201 | ar | LND |  |  |  |  |  |  |
|  | N | **N Structural Steel** |  |  | 2008-03-03 | 2010-12-20 |  |  |  |  |  |  |  |  |  |  |  |  |  |  |  |  |  |  |  |  |  |  |  |  |
| EN151201 |  | CA12 ReactorStr SK1201-CAD Model/Concepts StrSte |  | 126d | 2008-03-03 A | 2008-08-29 A | AD2230 FF | 100% |  |  | EN151201 | EN151201 | 87B | 12 |  | 200 | E | LND | E | N | EN15 | 1201 | de | LND |  | N02D | 0 | 200 | N02D | 055 |
| EN21120105 |  | CA12 ReactorStr SK1201 - GA-Drwgs + Fdtn Loads |  | 126d | 2009-02-09 A | 2009-08-10 A | E3A0440 SS, E3A04A40 SF-10d, E3A0540 SS, EE46120105, E3A0740 SS, ER161201, EJ46120105, EN21130105 FF, EN151201 FF, AD2230 FS+30d, E3J0720 SS | 100% |  |  | EN21120105 | EN21120105 | 87B | 12 |  | 200 |  | LND | E | N | EN21 | 1201 | de | LND |  | N02D |  |  | N02D |  |
| EN24120105 |  | CA12 ReactorStr SK1201 - StaticCalc f.Fdtn Loads |  | 33d | 2009-08-17 A | 2009-09-30 A | EN21120105 | 100% |  |  | EN24120105 | EN24120105 | 87B | 12 |  | 200 |  | LND | E | N | EN24 | 1201 | de | LND |  | N02D |  |  | N02D |  |
| EN251201 |  | CA12 ReactorStr SK1201 - Loads for Civil | milestone | 0d | 2009-11-20 A | 2009-11-20 A | EN24120105 FF+37d | 100% |  |  | EN251201 | EN251201 | 87B | 12 |  | 200 | E | LND | E | N | EN25 | 1201 | de | LND |  | N02D | 0 | 200 | N02D | 055 |
| EN21120110 |  | CA12 ReactorStr SK1201 - GA-Drwgs + Final Loads |  | 137d | 2009-12-10 A | 2010-06-30 A | EE46120108 FF, EN21120105 FS+10d, EN251201 FS+34d, EB051201, EM051201, F4030 FF+30d, EJ46120108 FF, EN24120105 | 100% |  | TKB-S [1920 h] | EN21120110 | EN21120110 | 87B | 12 |  | 200 |  | LEI | E | N | EN21 | 1201 | de | LND | 1920,00 | N02D |  |  | N02D |  |
| EN24120110 |  | CA12 ReactorStr SK1201 - Final Static Calc |  | 139d | 2009-12-28 A | 2010-07-16 A | EN21120110 SS+10d | 100% |  | TKB-S [960 h] | EN24120110 | EN24120110 | 87B | 12 |  | 200 |  | LEI | E | N | EN24 | 1201 | de | LND | 960,00 | N02D |  |  | N02D |  |
| EN261201 |  | CA12 ReactorStr SK1201 -Layout dwgs input for KM |  | 78d | 2010-04-13 A | 2010-08-02 A | F4030 FF+5d, EN24120110 FF+5d | 100% |  | TKB-S [3600 h] | EN261201 | EN261201 | 87B | 12 |  | 200 |  | LEI | E | N | EN26 | 1201 | st | LND | 3600,00 | N02D |  |  | N02D |  |
| EN671201 |  | CA12 ReactorStr SK1201 - Grating Cut-Out drwgs |  | 114d | 2010-05-25 A | 2010-10-29 A | EN261201 FF+10d, F4460 FF+10d, ER421201 FF | 100% |  | TKB-S [1160 h] | EN671201 | EN671201 | 87B | 12 |  | 200 | C | LEI | E | N | EN67 | 1201 | de | LND | 1160,00 | N02D |  | 200 | N02D |  |
| EN801201 |  | CA12 ReactorStruc - Cladding drwgs |  | 13d | 2010-06-28 A | 2010-07-12 A | ER391201, HEN80 FF | 100% | TB26 - S - Constr-Sumpf | TKB-S [160 h] | EN801201 | EN801201 | 87B | 12 |  | 200 | C | SC | E | N | EN80 | 1201 | de | LND | 160,00 | N02D |  | 200 | N02D |  |
| EN27120105 |  | CA12 ReactorStr SK1201 - KM drwgs |  | 33d | 2010-07-28 A | 2010-09-10 A | EN261201, EN24120105 | 100% |  | KM Drwgs preparation by Cheljabinsk [702 t] | EN27120105 | EN27120105 | 87B | 12 |  | 200 |  | Chel | E | N | EN27 | 1201 | de | LND | 0,00 | N02D |  |  | N02D |  |
| EN27120110 |  | CA12 ReactorStr SK1201 - Check KM drwgs |  | 16d | 2010-09-13 A | 2010-10-04 A | EN27120105 | 100% |  |  | EN27120110 | EN27120110 | 87B | 12 |  | 200 |  | LEI | E | N | EN27 | 1201 | de | LND |  | N02D |  |  | N02D |  |
| EN281201 |  | CA12 ReactorStr SK1201 - Shop dwgs(KMD) by Vendor |  | 54d | 2010-10-05 A | 2010-12-20 A | EN27120110 | 100% |  |  | EN281201 | EN281201 | 87B | 12 |  | 200 |  | Chel | E | N | EN28 | 1201 | de | LND |  | N02D |  |  | N02D |  |
| EN641201 |  | CA12 ReactorStr SK1201 - Check Grating Cut-Out drwgs |  | 20d | 2010-10-06 A | 2010-11-02 A | EN671201 | 100% |  |  | EN641201 | EN641201 | 87B | 12 |  | 200 | C | LEI | E | N | EN67 | 1201 | de | LND |  | N02D |  | 200 | N02D |  |
| EN681201 |  | CA12 ReactorStr SK1201 - Grating Fabrication drwgs |  | 20d | 2010-10-06 A | 2010-11-02 A | EN671201, EN641201 FF | 100% |  |  | EN681201 | EN681201 | 87B | 12 |  | 200 | C | SC | E | N | EN68 | 1201 | de | LND |  | N02D |  | 200 | N02D |  |

Notes:
- EC441200: P3 Activity Log Info: incl. PMT approval
- EC44120005: P3 Activity Log Info: incl. PMT approval
- EC221201: P3 Activity Log Info: TKB-B Keyplan to Subcontractor
- EC45120105: P3 Activity Log Info: incl. PMT approval
- EC45120110: P3 Activity Log Info: incl. PMT approval

| ID | WBS | Activity | Type | Duration | Start | Finish | Predecessors | Complete | Cost | Actual cost | UDF_SAVE ACTID | UDF_SAVE ACT ID | Department | Type of Work | Constr. Area | Pro Unit/DocCode | Inquiry/Order No | PMT-Area | PMT-Schedule Org | PMT-Discipline | PMT-Phase | PMT-Stage | PMT-Respons. | Zeigen/n. Zeigen | WBS Phase | WBS Discipline | WBS Type of Work | WBS Objects | IMS | UPT | PMT-Doc. Type | UDF_CONTRACT START DATE | UDF_CONTRACT FINISH DATE | UDF_CONTRACT ITEM |
| --- | --- | --- | --- | --- | --- | --- | --- | --- | --- | --- | --- | --- | --- | --- | --- | --- | --- | --- | --- | --- | --- | --- | --- | --- | --- | --- | --- | --- | --- | --- | --- | --- | --- | --- |
|  | B | **B Mechanical - Stationary Equipment** |  |  | 2008-01-25 | 2009-01-24 |  |  |  |  |  |  |  |  |  |  |  |  |  |  |  |  |  |  |  |  |  |  |  |  |  |  |  |  |
| E3ALL120 |  | ALL1 React. w Agitators - Techn Eval./PO Spec. |  | 13d | 2008-01-25 A | 2008-02-12 A | P3ALL1C | 100% |  |  | E3ALL120 | E3ALL120 | 869 | ALL1 | 12 | DC | 2DC8440 | 200 | 200 | 400 | E | 3A | LND | C2 | E | B | EB34 | 1201 | 3 | LND |  |  |  |  |
| E3ALL130 |  | ALL1 React. w Agitators - Techn. Eval./Bid Tab F | milestone | 0d | 2008-01-26 A | 2008-01-26 A | F4910 FF | 100% |  |  | E3ALL130 | E3ALL130 | 869 | ALL1 | 12 | DC | 2DC8440 | 200 | 200 | 400 | E | 3A | LND | C2 | E | B | EB34 | 1201 | 3 | LND |  |  |  |  |
| E3ALL140 |  | ALL1 React. w Agitators- 1st Review Vendor Dwgs |  | 17d | 2008-04-08 A | 2008-04-30 A | P3ALL1D FS+37d | 100% |  |  | E3ALL140 | E3ALL140 | 869 | ALL1 | 12 | DC | 2DC8440 | 200 | 200 | 400 | E | 3A | LND | C2 | E | B | EB35 | 1201 | 3 | LND | DFA |  |  |  |
| E3ALL150 |  | ALL1 React. w Agitat. - Vendor dwgs approved | milestone | 0d | 2008-05-01 A | 2008-05-01 A | E3ALL140 FF | 100% | 1,029,700 | 1,029,700 | E3ALL150 | E3ALL150 | 869 | ALL1 | 12 | DC | 2DC8440 | 200 | 200 | 400 | E |  | LND | C2 | E | B | EB35 | 1201 | 3 | LND |  |  |  |  |
| E3ALL160 |  | ALL1 React. w Agitators- 2nd Review Vendor Dwgs |  | 25d | 2008-06-30 A | 2008-08-01 A | E3ALL140 FS+20d, E3ALL150 | 100% |  |  | E3ALL160 | E3ALL160 | 869 | ALL1 | 12 | DC | 2DC8440 | 200 | 200 | 400 | E |  | LND | C2 | E | B | EB35 | 1201 | 3 | LND |  |  |  |  |
| E3A0540 |  | A05 Offgas Cyclone&R - 1st Review Vendor Dwgs |  | 13d | 2008-07-29 A | 2008-08-14 A | P3A05D1 FS+18d | 100% |  |  | E3A0540 | E3A0540 | 869 | A05 | 12 | DC | 2DC8590 | 200 | 200 | 400 | E | 3A | LND | C2 | E | B | EB15 | 1201 | 3 | LND | DFA |  |  |  |
| EB051201 |  | CA12 ReactorStruc - Final Loads f.Civil/StSteel | milestone | 0d | 2009-01-24 A | 2009-01-24 A | E3ALL150, E3A0450, E3A0750, E3U1520 FF, E3A04A50 FF, E3A0120 SF | 100% |  |  | EB051201 | EB051201 | 869 |  | 12 |  |  | 200 |  |  |  |  | LND |  | E | B | EB05 | 1201 | 3 | LND |  |  |  |  |
|  | M | **M Mechanical - Rotating Equipment** |  |  | 2008-11-29 | 2008-11-29 |  |  |  |  |  |  |  |  |  |  |  |  |  |  |  |  |  |  |  |  |  |  |  |  |  |  |  |  |
| EM051201 |  | CA12 ReactorStruc - Final Loads f.Civil/StrSteel | milestone | 0d | 2008-11-29 A | 2008-11-29 A | E3M0540 SF, E3U1520 SF, E3ALL160, E3M0640, E3M1120 FF | 100% |  |  | EM051201 | EM051201 | 867 |  | 12 |  |  | 200 |  |  |  |  | LND |  | E | M | EM05 | 1201 | I | LND |  |  |  |  |
|  | R | **R Piping** |  |  | 2008-04-01 | 2011-02-04 |  |  |  |  |  |  |  |  |  |  |  |  |  |  |  |  |  |  |  |  |  |  |  |  |  |  |  |  |
| ER151201 |  | CA12 ReactorStruc - Conceptual Piping |  | 169d | 2008-04-01 A | 2008-11-28 A | F2760 | 100% |  |  | ER151201 | ER151201 | 876 |  | 12 |  |  | 200 |  |  |  |  | LND |  | E | R | ER15 | 1201 | PL | LND |  |  |  |  |
| ER301201 |  | CA12 ReactorStruc - CAD Model Piping / Eqpt |  | 517d | 2008-07-01 A | 2010-07-23 A | ER151201 SS, ER391201 FF+10d, A1KL1130A FF | 100% |  |  | ER301201 | ER301201 | 876 |  | 12 |  |  | 200 |  |  |  |  | LNI |  | E | R | ER30 | 1201 | PL | LND |  |  |  |  |
| ER161201 |  | CA12 ReactorStruc - prelim Loads for SteelStruc |  | 20d | 2009-01-05 A | 2009-01-30 A | ER151201 FF | 100% |  |  | ER161201 | ER161201 | 876 |  | 12 |  |  | 200 |  |  |  |  | LND |  | E | R | ER16 | 1201 | PL | LND |  |  |  |  |
| ER361201 |  | CA12 ReactorStruc - CAD Model Review 60% |  | 12d | 2009-11-02 A | 2009-11-17 A | F4030 SS | 100% |  |  | ER361201 | ER361201 | 876 |  | 12 |  |  | 200 |  |  |  |  | LND |  | E | R | ER36 | 1201 | 2 | LND |  |  |  |  |
| ER421201 |  | CA12 ReactorStruc - Stress Calculation |  | 98d | 2009-11-16 A | 2010-04-09 A | ER361201 | 100% |  |  | ER421201 | ER421201 | 872 |  | 12 |  |  | 200 |  |  |  |  | LND |  | E | R | ER42 | 1201 | PL | LND |  |  |  |  |
| ER191201 |  | CA12 ReactorStruc - Final Loads for SteelStruc | milestone | 0d | 2010-02-01 A | 2010-02-01 A | F4030 SF+20d, EN21120110 FF-20d, ER161201 | 100% |  |  | ER191201 | ER191201 | 876 |  | 12 |  |  | 200 |  |  |  |  | LNI |  | E | R | ER19 | 1201 | PL | LND |  |  |  |  |
| ER391201 |  | CA12 ReactorStruc - CAD Model Review 90% |  | 10d | 2010-06-28 A | 2010-07-09 A | F4460 FF | 100% |  |  | ER391201 | ER391201 | 876 |  | 12 |  |  | 200 |  |  |  |  | LND |  | E | R | ER39 | 1201 | 3 | LND |  |  |  |  |
| ER451201 |  | CA12 ReactorStruc - Piping Isometrics |  | 119d | 2010-07-05 A | 2010-12-17 A | ER391201 FF+25d, ER421201, ER301201 FF+10d | 100% |  |  | ER451201 | ER451201 | 876 |  | 12 |  |  | 200 |  |  |  |  | LEI |  | E | R | ER45 | 1201 | 5 | LND |  |  |  |  |
| ER491201 |  | CA12 ReactorStruc - Design Check / Rel.Isos&BOM |  | 120d | 2010-08-18 A | 2011-02-04 A | ER451201 SS+20d | 100% |  |  | ER491201 | ER491201 | 876 |  | 12 |  |  | 200 |  |  |  |  | LEI |  | E | R | ER49 | 1201 | 5 | LND |  |  |  |  |
|  | E | **E Electrical** |  |  | 2008-10-06 | 2010-07-30 |  |  |  |  |  |  |  |  |  |  |  |  |  |  |  |  |  |  |  |  |  |  |  |  |  |  |  |  |
| EE46120105 |  | CA12 ReactorStruc - prelimLoads f.Civil/StrSteel |  | 15d | 2008-10-06 A | 2008-10-24 A | F3060 FF | 100% |  |  | EE46120105 | EE46120105 | 874 |  | 12 |  |  |  |  |  | E |  | LND |  | E | E | EE11 | 1201 | E | LND |  | 2011-05-20 | 2011-10-30 | E-16-07-02 |
| EE901201 |  | CA12 ReactorStruc - Earthing Details |  | 30d | 2009-05-07 A | 2009-06-19 A | EE903110 FS+20d | 100% |  |  | EE901201 | EE901201 | 874 |  | 12 |  |  |  |  |  | E |  | LND |  | E | E | EE90 | 1201 | E | LND |  | 2011-05-20 | 2011-10-30 | E-16-07-02 |
| EE46120110 |  | CA12 ReactorStruc - El. CableTray Layout Pl. / LOP's 1st Issue |  | 162d | 2009-12-07 A | 2010-07-30 A | EE460000, F4030 FF+75d | 100% |  |  | EE46120110 | EE46120110 | 874 |  | 12 |  |  |  |  |  | E |  | LEI |  | E | E | EE46 | 1201 | E | LND |  | 2011-05-20 | 2011-10-30 | E-16-07-02 |
| EE561201 |  | CA12 ReactorStruc - Cable Pulling Details |  | 159d | 2009-12-10 A | 2010-07-30 A | EE46120110 FF, EE500130 | 100% |  |  | EE561201 | EE561201 | 874 |  | 12 |  |  |  |  |  | E |  | LEI |  | E | E | EE56 | 1201 | E | LND |  | 2011-05-20 | 2012-02-10 | E-16-01-01 |
| EE46120108 |  | CA12 ReactorStruc - Final Loads f.Civil/StrSteel |  | 51d | 2009-12-14 A | 2010-02-26 A | EE46120105 | 100% |  |  | EE46120108 | EE46120108 | 874 |  | 12 |  |  |  |  |  | E |  | LEI |  | E | E | EE12 | 1201 | E | LND |  | 2011-05-20 | 2011-10-30 | E-16-07-02 |

Notes:
- E3ALL150: Expenses: 900A 1029700
- ER161201: P3 Activity Log Info: incl. Stress Calc for Civil Supports
- EE561201: P3 Activity Log Info: UG/Above Ground Details

| ID | WBS | Activity | Type | Duration | Start | Finish | Predecessors | Complete | Resources | UDF_SAVE ACTID | UDF_SAVE ACT ID | Department | Constr. Area | Pro Unit/DocCode | PMT-Phase | PMT-Respons. | WBS Phase | WBS Discipline | WBS Type of Work | WBS Objects | IMS | UPT | PMT-Area | PMT-Schedule Org | Type of Work | Inquiry/Order No | PMT-Discipline | Zeigen/n. Zeigen | TB26 Ressource Budget |
| --- | --- | --- | --- | --- | --- | --- | --- | --- | --- | --- | --- | --- | --- | --- | --- | --- | --- | --- | --- | --- | --- | --- | --- | --- | --- | --- | --- | --- | --- |
|  | J | **J Instrumentation** |  |  | 2008-10-06 | 2010-11-26 |  |  |  |  |  |  |  |  |  |  |  |  |  |  |  |  |  |  |  |  |  |  |  |
| EJ46120105 |  | CA12 ReactorStruc - prelimLoads f.Civil/StrSteel |  | 15d | 2008-10-06 A | 2008-10-24 A | F3060 FF | 100% |  | EJ46120105 | EJ46120105 | 86E | 12 | 999 | E | LND | E | J | EJ11 | 1201 | I | LND |  |  |  |  |  |  |  |
| EJ361201 |  | CA12 ReactorStruc - Hook-Up drwgs 1st Issue |  | 90d | 2010-02-03 A | 2010-06-14 A | A1EJ0080, F4030 FS+50d | 100% |  | EJ361201 | EJ361201 | 86E | 12 | 999 | C | LEI | E | J | EJ36 | 1201 | I | LND | 200 | 200 |  |  |  |  |  |
| EJ46120108 |  | CA12 ReactorStruc - Final Loads f.Civil/StrSteel |  | 10d | 2010-02-15 A | 2010-02-26 A | EJ46120105 | 100% |  | EJ46120108 | EJ46120108 | 86E | 12 | 999 | E | LEI | E | J | EJ12 | 1201 | I | LND |  |  |  |  |  |  |  |
| EJ46120110 |  | CA12 ReactorStruc - Instr Cable Tray Layout Pl. 1st Issue |  | 106d | 2010-03-01 A | 2010-07-30 A | F4030 FF, EE46120110 FF | 100% |  | EJ46120110 | EJ46120110 | 86E | 12 | 999 | E | LEI | E | J | EJ41 | 1201 | I | LND |  |  |  |  |  |  |  |
| EJ321201 |  | CA12 ReactorStruc - JB Location drwgs |  | 25d | 2010-07-12 A | 2010-08-13 A | F4460 FF+25d, F4030 | 100% |  | EJ321201 | EJ321201 | 86E | 12 | 999 | C | LEI | E | J | EJ37 | 1201 | I | LND | 200 | 200 |  |  |  |  |  |
| EJ801201 |  | CA12 ReactorStruc - Loop Diagrams |  | 70d | 2010-08-20 A | 2010-11-26 A | A1EJ0040 SF, EJ800010 | 100% |  | EJ801201 | EJ801201 | 86E | 12 | 999 | E | LEI | E | J | EJ80 | 1201 | I | LND |  |  |  |  |  |  |  |
|  | 1204 | **1204 Connection Structure Reactor to Teal Bldg - CA12** |  |  | 2008-03-03 | 2011-02-04 |  |  |  |  |  |  |  |  |  |  |  |  |  |  |  |  |  |  |  |  |  |  |  |
|  | C | **C Civil** |  |  | 2009-12-14 | 2010-09-30 |  |  |  |  |  |  |  |  |  |  |  |  |  |  |  |  |  |  |  |  |  |  |  |
| EC221204 |  | CA12 TealStr SK1202/4 - Layout Drwg / Loads IFD |  | 25d | 2009-12-14 A | 2010-01-21 A | EN251204 FF | 100% |  | EC221204 | EC221204 | 87A | 12 | 1204C01 | E | LND | E | C | EC22 | 1204 | de | LND | 200 | 200 |  |  |  |  |  |
| EC261204 |  | CA12 TealStr to TealBldg - Civil Static Calculation |  | 154d | 2010-01-22 A | 2010-08-31 A | EC221204, EC261201 SS+15d, P3C0BD FS+10d | 100% |  | EC261204 | EC261204 | 87A | 12 | 1204C14 | E | IPR | E | C | EC26 | 1204 | de | LND | 200 | 200 |  |  |  |  |  |
| EC45120405 |  | CA12 TealStr to TealBldg - Civil Layout drwgs AFC |  | 107d | 2010-01-22 A | 2010-06-25 A | P3C0BD FS+10d, HEC45C FF, EC261204 SS, AD2230, EC221204 | 100% |  | EC45120405 | EC45120405 | 87A | 12 | 1204C13 | E | IPR | E | C | EC45 | 1204 | ar | LND | 200 |  |  |  |  |  |  |
| EC151204 |  | CA12 TealStr to TealBldg - Piling drwgs AFC |  | 26d | 2010-02-05 A | 2010-03-12 A | EC261204 SS+10d | 100% |  | EC151204 | EC151204 | 87A | 12 | 1204C16 |  | IPR | E | C | EC15 | 1204 | PI | LND | 200 |  |  |  |  |  |  |
| EC28120406 |  | CA12 TealStr to TealBldg - Precast Formw/Reinf drwgs AFC |  | 156d | 2010-02-19 A | 2010-09-30 A | EC28120410 FF+20d | 100% |  | EC28120406 | EC28120406 | 87A | 12 | 1204C53 | E | IPR | E | C | EC28 | 1204 | PRE | LND | 200 | 200 |  |  |  |  |  |
| EC28120410 |  | CA12 TealStr to TealBldg - Formw/Reinf dwgs Found. AFC |  | 90d | 2010-02-19 A | 2010-06-30 A | EC151204 SS+10d, EC261204 SS+20d | 100% |  | EC28120410 | EC28120410 | 87A | 12 | 1204C21 | E | IPR | E | C | EC28 | 1204 | cq | LND | 200 | 200 |  |  |  |  |  |
| EC45120410 |  | CA12 TealStr to TealBldg - Civil Layout drwgs IFC | milestone | 0d | 2010-05-17 A | 2010-05-17 A | EC45120405 FF-14d | 100% |  | EC45120410 | EC45120410 | 87A | 12 |  | E | IPR | E | C | EC45 | 1204 | ar | LND | 200 |  |  |  |  |  |  |
|  | N | **N Structural Steel** |  |  | 2008-03-03 | 2010-12-27 |  |  |  |  |  |  |  |  |  |  |  |  |  |  |  |  |  |  |  |  |  |  |  |
| EN151204 |  | CA12 TealStr SK1204-CADModel/Concepts StrSteel |  | 126d | 2008-03-03 A | 2008-08-29 A | AD2230 FF | 100% |  | EN151204 | EN151204 | 87B | 12 |  | E | LND | E | N | EN15 | 1204 | de | LND | 200 | 200 | N02E | N02E | 055 | 0 |  |
| EN21120405 |  | CA12 TealStr SK1204 - GA-Drwgs + Fdtn Loads |  | 131d | 2009-02-23 A | 2009-08-31 A | ER161204, EE46120405, EN151204 FF, AD2230 FS+40d, EJ46120405 | 100% |  | EN21120405 | EN21120405 | 87B | 12 |  |  | LND | E | N | EN21 | 1204 | de | LND | 200 |  | N02E | N02E |  |  |  |
| EN24120405 |  | CA12 TealStr SK1204 - Static Calc f.Fdtn Loads |  | 20d | 2009-10-12 A | 2009-11-06 A | EN21120405 | 100% | TKB-S [160 h] | EN24120405 | EN24120405 | 87B | 12 |  |  | LND | E | N | EN24 | 1204 | de | LND | 200 |  | N02E | N02E |  |  | 160,00 |
| EN251204 |  | CA12 TealStr SK1204 - Loads for Civil | milestone | 0d | 2009-11-23 A | 2009-11-23 A | EN24120405 FF+10d | 100% |  | EN251204 | EN251204 | 87B | 12 |  | E | LND | E | N | EN25 | 1204 | de | LND | 200 | 200 | N02E | N02E | 055 | 0 |  |
| EN21120410 |  | CA12 TealStr SK1204 - GA-Drwgs + Final Loads |  | 96d | 2009-12-28 A | 2010-05-17 A | F4030 FS+38d, EN21120405 FS+10d, EN24120405, EJ46120408 FF, EE46120408, EN251204 | 100% | TKB-S [480 h] | EN21120410 | EN21120410 | 87B | 12 |  |  | LEI | E | N | EN21 | 1204 | de | LND | 200 |  | N02E | N02E |  |  | 480,00 |
| EN24120410 |  | CA12 TealStr SK1204 - Final Static Calc |  | 125d | 2009-12-28 A | 2010-06-28 A | ER191204 FF, EN21120410 SS | 100% | TKB-S [320 h] | EN24120410 | EN24120410 | 87B | 12 |  |  | LEI | E | N | EN24 | 1204 | de | LND | 200 |  | N02E | N02E |  |  | 320,00 |
| EN671204 |  | CA12 TealStr SK1204 - Grating Cut-Out drwgs |  | 96d | 2010-05-25 A | 2010-10-05 A | F4460 FF+10d, EN261204 FF+10d, ER421204 FF | 100% | TKB-S [240 h] | EN671204 | EN671204 | 87B | 12 |  | C | LEI | E | N | EN67 | 1204 | de | LND | 200 | 200 | N02E | N02E |  |  | 240,00 |
| EN261204 |  | CA12 TealStr SK1204 - Layout drwgs input for KM |  | 29d | 2010-05-27 A | 2010-07-06 A | EN24120410 FF-5d, F4030 FF+20d | 100% | TKB-S [960 h] | EN261204 | EN261204 | 87B | 12 |  |  | LEI | E | N | EN26 | 1204 | st | LND | 200 |  | N02E | N02E |  |  | 960,00 |
| EN27120405 |  | CA12 TealStr SK1204 - KM drwgs |  | 53d | 2010-07-07 A | 2010-09-17 A | EN261204, EN24120405 | 100% | KM Drwgs preparation by Cheljabinsk [60 t] | EN27120405 | EN27120405 | 87B | 12 |  |  | Chel | E | N | EN27 | 1204 | de | LND | 200 |  | N02E | N02E |  |  | 0,00 |
| EN27120410 |  | CA12 TealStr SK1204 - Check KM drwgs |  | 10d | 2010-09-20 A | 2010-10-01 A | EN27120405 | 100% |  | EN27120410 | EN27120410 | 87B | 12 |  |  | LEI | E | N | EN27 | 1204 | de | LND | 200 |  | N02E | N02E |  |  |  |
| EN281204 |  | CA12 TealStr SK1204 - Shop dwgs(KMD) by Vendor |  | 52d | 2010-10-04 A | 2010-12-15 A | EN27120410 | 100% |  | EN281204 | EN281204 | 87B | 12 |  |  | Chel | E | N | EN28 | 1204 | de | LND | 200 |  | N02E | N02E |  |  |  |
| EN641204 |  | CA12 TealStr SK1204 - Check Grating Cut-Out drwgs |  | 13d | 2010-10-06 A | 2010-10-22 A | EN671204 | 100% |  | EN641204 | EN641204 | 87B | 12 |  | C | LEI | E | N | EN67 | 1204 | de | LND | 200 | 200 | N02E | N02E |  |  |  |
| EN681204 |  | CA12 TealStr SK1204 -Grating Fabrication drwgs |  | 25d | 2010-11-22 A | 2010-12-27 A | EN671204, EN261204 FF+10d, EN641204 FF | 100% |  | EN681204 | EN681204 | 87B | 12 |  | C | SC | E | N | EN68 | 1204 | de | LND | 200 | 200 | N02E | N02E |  |  |  |

Notes:
- EC221204: P3 Activity Log Info: TKB-B Keyplan to Subcontractor
- EC45120405: P3 Activity Log Info: incl. PMT approval
- EC45120410: P3 Activity Log Info: incl. PMT approval

| ID | WBS | Activity | Type | Duration | Start | Finish | Predecessors | Complete | UDF_SAVE ACTID | UDF_SAVE ACT ID | Department | Constr. Area | PMT-Area | PMT-Respons. | WBS Phase | WBS Discipline | WBS Type of Work | WBS Objects | IMS | UPT | UDF_CONTRACT START DATE | UDF_CONTRACT FINISH DATE | UDF_CONTRACT ITEM | PMT-Phase | Pro Unit/DocCode | PMT-Schedule Org |
| --- | --- | --- | --- | --- | --- | --- | --- | --- | --- | --- | --- | --- | --- | --- | --- | --- | --- | --- | --- | --- | --- | --- | --- | --- | --- | --- |
|  | R | **R Piping** |  |  | 2008-04-01 | 2011-02-04 |  |  |  |  |  |  |  |  |  |  |  |  |  |  |  |  |  |  |  |  |
| ER151204 |  | CA12 TealStr SK1202/4 - Conceptual Piping |  | 169d | 2008-04-01 A | 2008-11-28 A | F2760 | 100% | ER151204 | ER151204 | 876 | 12 | 200 | LND | E | R | ER15 | 1204 | PL | LND |  |  |  |  |  |  |
| ER301204 |  | CA12 TealStr SK1202/4 - CAD Model Piping / Eqpt |  | 517d | 2008-07-01 A | 2010-07-23 A | ER151204 SS, ER391204 FF+10d | 100% | ER301204 | ER301204 | 876 | 12 | 200 | LNI | E | R | ER30 | 1204 | PL | LND |  |  |  |  |  |  |
| ER161204 |  | CA12 TealStr SK1202/4-prel Loads for Steel Struc |  | 20d | 2009-01-05 A | 2009-01-30 A | ER151204 FF | 100% | ER161204 | ER161204 | 876 | 12 | 200 | LND | E | R | ER16 | 1204 | PL | LND |  |  |  |  |  |  |
| ER361204 |  | CA12 TealStr SK1202/4 - CAD Model Review 60% |  | 12d | 2009-11-02 A | 2009-11-17 A | F4030 SS | 100% | ER361204 | ER361204 | 876 | 12 | 200 | LND | E | R | ER36 | 1204 | 2 | LND |  |  |  |  |  |  |
| ER421204 |  | CA12 TealStr SK1202/4 - Stress Calculation |  | 98d | 2009-11-16 A | 2010-04-09 A | ER361204 | 100% | ER421204 | ER421204 | 872 | 12 | 200 | LND | E | R | ER42 | 1204 | PL | LND |  |  |  |  |  |  |
| ER191204 |  | CA12 TealStr SK1204- Fin Loads for Steel Struc | milestone | 0d | 2010-02-15 A | 2010-02-15 A | EN21120410 FF-10d, F4030 SF+20d, ER161204 FF | 100% | ER191204 | ER191204 | 876 | 12 | 200 | LNI | E | R | ER19 | 1204 | PL | LND |  |  |  |  |  |  |
| ER391204 |  | CA12 TealStr SK1202/4 - CAD Model Review 90% |  | 10d | 2010-06-28 A | 2010-07-09 A | F4460 FF, HER39 FF | 100% | ER391204 | ER391204 | 876 | 12 | 200 | LND | E | R | ER39 | 1204 | 3 | LND |  |  |  |  |  |  |
| ER451204 |  | CA12 TealStr SK1202/4- Piping Isometrics |  | 114d | 2010-07-12 A | 2010-12-17 A | ER421204, ER301204 FF+20d, ER391204 | 100% | ER451204 | ER451204 | 876 | 12 | 200 | LEI | E | R | ER45 | 1204 | 5 | LND |  |  |  |  |  |  |
| ER491204 |  | CA12 TealStr SK1202/4-Design Check/ Rel.Isos&BOM |  | 110d | 2010-09-01 A | 2011-02-04 A | ER451204 SS+20d | 100% | ER491204 | ER491204 | 876 | 12 | 200 | LEI | E | R | ER49 | 1204 | 5 | LND |  |  |  |  |  |  |
|  | E | **E Electrical** |  |  | 2008-10-06 | 2010-07-30 |  |  |  |  |  |  |  |  |  |  |  |  |  |  |  |  |  |  |  |  |
| EE46120405 |  | CA12 TealStr SK1202/4-prelim Loads f.Struc Steel |  | 15d | 2008-10-06 A | 2008-10-24 A | F3060 FF | 100% | EE46120405 | EE46120405 | 874 | 12 |  | LND | E | E | EE11 | 1204 | E | LND | 2011-05-10 | 2011-12-10 | E-16-07-03 | E |  |  |
| EE901204 |  | CA12 TealStr SK1202/4-Earthing Details |  | 30d | 2009-06-22 A | 2009-07-31 A | EE901201 | 100% | EE901204 | EE901204 | 874 | 12 |  | LND | E | E | EE90 | 1204 | E | LND | 2011-05-10 | 2011-12-10 | E-16-07-03 | E |  |  |
| EE46120408 |  | CA12 TealStr SK1202/4 -Final Loads f.Struc Steel |  | 20d | 2009-08-31 A | 2009-09-25 A | EE46120405 FF-30d | 100% | EE46120408 | EE46120408 | 874 | 12 |  | LEI | E | E | EE12 | 1204 | E | LND | 2011-05-10 | 2011-12-10 | E-16-07-03 | E |  |  |
| EE46120410 |  | CA12 TealStr SK1202/4-El. CableTray Layout Pl. 1st Issue |  | 162d | 2009-12-07 A | 2010-07-30 A | EE460000, F4030 FF+75d | 100% | EE46120410 | EE46120410 | 874 | 12 |  | LEI | E | E | EE46 | 1204 | E | LND | 2011-05-10 | 2011-12-10 | E-16-07-03 | E |  |  |
| EE561204 |  | CA12 TealStr SK1202/4 - Cable Pulling Details |  | 159d | 2009-12-10 A | 2010-07-30 A | EE46120410 FF, EE500130 | 100% | EE561204 | EE561204 | 874 | 12 |  | LEI | E | E | EE56 | 1204 | E | LND | 2011-05-10 | 2011-12-10 | E-16-07-03 | E |  |  |
|  | J | **J Instrumentation** |  |  | 2008-10-06 | 2010-07-30 |  |  |  |  |  |  |  |  |  |  |  |  |  |  |  |  |  |  |  |  |
| EJ46120405 |  | CA12 TealStr SK1202/4-prelim Loads f.Struc Steel |  | 15d | 2008-10-06 A | 2008-10-24 A | F3060 FF | 100% | EJ46120405 | EJ46120405 | 86E | 12 |  | LND | E | J | EJ11 | 1204 | I | LND |  |  |  | E | 999 |  |
| EJ46120408 |  | CA12 TealStr SK1202/4 -Final Loads f.Struc Steel |  | 10d | 2010-02-15 A | 2010-02-26 A | EJ46120405 | 100% | EJ46120408 | EJ46120408 | 86E | 12 |  | LEI | E | J | EJ12 | 1204 | I | LND |  |  |  | E | 999 |  |
| EJ46120410 |  | CA12 TealStr SK1202/4-Instr CableTray Layout Pl. 1st Issue |  | 106d | 2010-03-01 A | 2010-07-30 A | F4030 FF, EE46120410 FF, F4460 | 100% | EJ46120410 | EJ46120410 | 86E | 12 |  | LEI | E | J | EJ41 | 1204 | I | LND |  |  |  | E | 999 |  |
|  | 1205 | **1205 Agitator Removable Unit - CA12** |  |  | 2008-03-03 | 2010-12-20 |  |  |  |  |  |  |  |  |  |  |  |  |  |  |  |  |  |  |  |  |
|  | C | **C Civil** |  |  | 2009-12-14 | 2010-08-20 |  |  |  |  |  |  |  |  |  |  |  |  |  |  |  |  |  |  |  |  |
| EC221205 |  | CA12 AgitatorRemUnit - Layout Drwg / Loads IFD |  | 25d | 2009-12-14 A | 2010-01-21 A | EC441200 FF, EN251205 FF | 100% | EC221205 | EC221205 | 87A | 12 | 200 | LND | E | C | EC22 | 1205 | de | LND |  |  |  | E | 1205C01 | 200 |
| EC261205 |  | CA12 AgitatorRemUnit - Civil Static Calculation |  | 147d | 2010-01-22 A | 2010-08-20 A | EC261201 SS+10d, EC221205, P3C0BD FS+10d | 100% | EC261205 | EC261205 | 87A | 12 | 200 | IPR | E | C | EC26 | 1205 | de | LND |  |  |  | E | 1205C14 | 200 |
| EC45120505 |  | CA12 AgitatorRemUnit - Civil Layout drwgs AFC |  | 110d | 2010-01-22 A | 2010-06-30 A | EC261205 SS, EC221205, HEC45C FF, P3C0BD FS+10d | 100% | EC45120505 | EC45120505 | 87A | 12 | 200 | IPR | E | C | EC45 | 1205 | ar | LND |  |  |  | E | 1205C13 |  |
| EC151205 |  | CA12 AgitatorRemUnit - Piling drwgs AFC |  | 26d | 2010-02-05 A | 2010-03-12 A | EC261205 SS+10d | 100% | EC151205 | EC151205 | 87A | 12 | 200 | IPR | E | C | EC15 | 1205 | PI | LND |  |  |  |  | 1205C16 |  |
| EC281205 |  | CA12 AgitatorRemUnit - Formw/Reinforce drwgs AFC |  | 92d | 2010-02-19 A | 2010-07-02 A | EC45120505 SS, EC261205 SS+10d | 100% | EC281205 | EC281205 | 87A | 12 | 200 | IPR | E | C | EC28 | 1205 | cq | LND |  |  |  | E | 1205C21 | 200 |
| EC45120510 |  | CA12 AgitatorRemUnit - Civil Layout drwgs IFC | milestone | 0d | 2010-05-18 A | 2010-05-18 A | EC45120505 FF-14d | 100% | EC45120510 | EC45120510 | 87A | 12 | 200 | IPR | E | C | EC45 | 1205 | ar | LND |  |  |  | E |  |  |

Notes:
- EC221205: P3 Activity Log Info: TKB-B Keyplan to Subcontractor
- EC45120505: P3 Activity Log Info: incl. PMT approval
- EC45120510: P3 Activity Log Info: incl. PMT approval

| ID | WBS | Activity | Type | Duration | Start | Finish | Predecessors | Complete | Resources | UDF_SAVE ACTID | UDF_SAVE ACT ID | Department | Type of Work | Constr. Area | Inquiry/Order No | PMT-Area | PMT-Schedule Org | PMT-Discipline | PMT-Phase | PMT-Respons. | Zeigen/n. Zeigen | WBS Phase | WBS Discipline | WBS Type of Work | WBS Objects | IMS | UPT | TB26 Ressource Budget | Pro Unit/DocCode |
| --- | --- | --- | --- | --- | --- | --- | --- | --- | --- | --- | --- | --- | --- | --- | --- | --- | --- | --- | --- | --- | --- | --- | --- | --- | --- | --- | --- | --- | --- |
|  | N | **N Structural Steel** |  |  | 2008-03-03 | 2010-12-20 |  |  |  |  |  |  |  |  |  |  |  |  |  |  |  |  |  |  |  |  |  |  |  |
| EN151205 |  | CA12 Agitator SK1205 -CADModel/Concepts StrSteel |  | 126d | 2008-03-03 A | 2008-08-29 A | AD2230 FF | 100% |  | EN151205 | EN151205 | 87B | N02F | 12 | N02F | 200 | 200 | 055 | E | LND | 0 | E | N | EN15 | 1205 | de | LND |  |  |
| EN21120505 |  | CA12 Agitator SK1205 - GA-Drwgs + Fdtn Loads |  | 15d | 2009-02-23 A | 2009-03-13 A | E3M1120 FF, EN151205, AD2230 FS+40d, E3J0720 SF, E3ALL140 SS | 100% |  | EN21120505 | EN21120505 | 87B | N02F | 12 | N02F | 200 |  |  | E | LND |  | E | N | EN21 | 1205 | de | LND |  |  |
| EN24120505 |  | CA12 Agitator SK1205 - Static Calc f.Fdtn Loads |  | 25d | 2009-08-24 A | 2009-09-25 A | EN21120505 | 100% | TKB-S [240 h] | EN24120505 | EN24120505 | 87B | N02F | 12 | N02F | 200 |  |  | E | LND |  | E | N | EN24 | 1205 | de | LND | 240,00 |  |
| EN251205 |  | CA12 Agitator SK1205 - Loads for Civil | milestone | 0d | 2009-11-02 A | 2009-11-02 A | EN24120505 FF+20d, HEN25 FF | 100% |  | EN251205 | EN251205 | 87B | N02F | 12 | N02F | 200 | 200 | 055 | E | LND | 0 | E | N | EN25 | 1205 | de | LND |  |  |
| EN21120510 |  | CA12 Agitator SK1205 - GA-Drwgs + Final Loads |  | 140d | 2009-12-10 A | 2010-07-05 A | HEN21 FF, EN21120505, EB051205, EM051205, EN21120110 SS+15d | 100% | TKB-S [640 h] | EN21120510 | EN21120510 | 87B | N02F | 12 | N02F | 200 |  |  | E | LEI |  | E | N | EN21 | 1205 | de | LND | 640,00 |  |
| EN24120510 |  | CA12 Agitator SK1205 - Final Static Calc |  | 155d | 2009-12-23 A | 2010-08-06 A | EN21120510 SS+10d | 100% | TKB-S [320 h] | EN24120510 | EN24120510 | 87B | N02F | 12 | N02F | 200 |  |  | E | LEI |  | E | N | EN24 | 1205 | de | LND | 320,00 |  |
| EN261205 |  | CA12 Agitator SK1205 - Layout dwgs input for KM |  | 57d | 2010-05-26 A | 2010-08-12 A | EN24120510 FF, F4030 FF+20d, HEN26 FF | 100% | TKB-S [1120 h] | EN261205 | EN261205 | 87B | N02F | 12 | N02F | 200 |  |  | E | LEI |  | E | N | EN26 | 1205 | st | LND | 1120,00 |  |
| EN671205 |  | CA12 Agitator SK1205 - Grating Cut-Out drwgs |  | 123d | 2010-05-26 A | 2010-11-12 A | EN261205 SS+10d, F4460 FF+10d | 100% | TKB-S [720 h] | EN671205 | EN671205 | 87B | N02F | 12 | N02F | 200 | 200 |  | C | LEI |  | E | N | EN67 | 1205 | de | LND | 720,00 |  |
| EN27120505 |  | CA12 Agitator SK1205 - KM drwgs |  | 43d | 2010-08-13 A | 2010-10-12 A | EN261205, EN24120505 | 100% | KM Drwgs preparation by Cheljabinsk [115 t] | EN27120505 | EN27120505 | 87B | N02F | 12 | N02F | 200 |  |  | E | Chel |  | E | N | EN27 | 1205 | de | LND | 0,00 |  |
| EN27120510 |  | CA12 Agitator SK1205 - Check KM drwgs |  | 9d | 2010-10-13 A | 2010-10-25 A | EN27120505 | 100% |  | EN27120510 | EN27120510 | 87B | N02F | 12 | N02F | 200 |  |  |  | LEI |  | E | N | EN27 | 1205 | de | LND |  |  |
| EN281205 |  | CA12 Agitator SK1205 - Shop dwgs(KMD) by Vendor |  | 29d | 2010-11-01 A | 2010-12-10 A | IMS-E-000180 FF, EN27120510 FS+5d, HEN28 FF | 100% |  | EN281205 | EN281205 | 87B | N02F | 12 | N02F | 200 |  |  | E | Chel |  | E | N | EN28 | 1205 | de | LND |  |  |
| EN641205 |  | CA12 Agitator SK1205 - Check Grating Cut-Out drwgs |  | 10d | 2010-11-15 A | 2010-11-29 A | EN671205, EN641201 | 100% |  | EN641205 | EN641205 | 87B | N02F | 12 | N02F | 200 | 200 |  | C | LEI |  | E | N | EN67 | 1205 | de | LND |  |  |
| EN681205 |  | CA12 Agitator SK1205 -Grating Fabrication drwgs |  | 15d | 2010-11-30 A | 2010-12-20 A | EN641205, EN671205, HEN68 FF | 100% |  | EN681205 | EN681205 | 87B | N02F | 12 | N02F | 200 | 200 |  | C | SC |  | E | N | EN68 | 1205 | de | LND |  |  |
|  | B | **B Mechanical - Stationary Equipment** |  |  | 2008-12-20 | 2008-12-20 |  |  |  |  |  |  |  |  |  |  |  |  |  |  |  |  |  |  |  |  |  |  |  |
| EB051205 |  | CA13 AgitatorRemUn - Final Loads for Struc Steel | milestone | 0d | 2008-12-20 A | 2008-12-20 A | E3ALL140, E3J0720 SF | 100% |  | EB051205 | EB051205 | 869 |  | 12 |  | 200 |  |  |  | LND |  | E | B | EB05 | 1205 | 3 | LND |  |  |
|  | M | **M Mechanical - Rotating Equipment** |  |  | 2008-11-04 | 2008-11-04 |  |  |  |  |  |  |  |  |  |  |  |  |  |  |  |  |  |  |  |  |  |  |  |
| EM051205 |  | CA13 AgitatorRemUn - Final Loads for Struc Steel | milestone | 0d | 2008-11-04 A | 2008-11-04 A | E3M1120 FF | 100% |  | EM051205 | EM051205 | 867 |  | 12 |  | 200 |  |  |  | LND |  | E | M | EM05 | 1205 | I | LND |  |  |
|  | 1221 | **1221 Catalyst Building Line 1 - CA12** |  |  | 2008-03-03 | 2011-04-04 |  |  |  |  |  |  |  |  |  |  |  |  |  |  |  |  |  |  |  |  |  |  |  |
|  | 0B | **0B General Activities** |  |  | 2009-01-03 | 2009-01-03 |  |  |  |  |  |  |  |  |  |  |  |  |  |  |  |  |  |  |  |  |  |  |  |
| E0201221 |  | CA12 Catalyst Bldg - freeze construction concept | milestone | 0d | 2009-01-03 A | 2009-01-03 A | F3600 | 100% |  | E0201221 | E0201221 | 87A |  | 12 |  | 200 |  |  | E |  |  | E | 0B | E020 | 1221 | INS | LND |  |  |
|  | C | **C Civil** |  |  | 2008-03-03 | 2011-02-28 |  |  |  |  |  |  |  |  |  |  |  |  |  |  |  |  |  |  |  |  |  |  |  |
| EC421221 |  | CA12 Catalyst Bldg - Building Concept |  | 171d | 2008-03-03 A | 2008-11-04 A | F2760 | 100% |  | EC421221 | EC421221 | 87A |  | 12 |  | 200 |  |  |  | LND |  | E | C | EC42 | 1221 | cq | LND |  |  |
| EC241221 |  | CA12 Catalyst Bldg - Foundation Data Sheets Eqpt |  | 15d | 2009-07-31 A | 2009-08-21 A | ER161221, EM051221, EB051221 | 100% |  | EC241221 | EC241221 | 87A |  | 12 |  | 200 |  |  |  | LND |  | E | C | EC24 | 1221 | de | LND |  |  |
| EC441221 |  | CA12 Catalyst Bldg - Building Layout drwgs IFD |  | 25d | 2009-12-08 A | 2010-01-15 A | AD2230 FF+30d, EC221221 FF, E0201221, EC421221 | 100% |  | EC441221 | EC441221 | 87A |  | 12 |  | 200 |  |  |  | LND |  | E | C | EC44 | 1221 | de | LND |  | 1206C01 |
| EC221221 |  | CA12 Catalyst Bldg - Civil Foundation Loads Bldg |  | 20d | 2009-12-15 A | 2010-01-15 A | EJ46122108 FF, EC241221 FF, ER161221, EE46122108 | 100% |  | EC221221 | EC221221 | 87A |  | 12 |  | 200 | 200 |  | E | LND |  | E | C | EC22 | 1221 | de | LND |  |  |
| EC131221 |  | CA12 Catalyst Bldg - Fire Safety Survey Report |  | 253d | 2010-01-18 A | 2011-01-14 A | EC461221 SS | 100% |  | EC131221 | EC131221 | 87A |  | 12 |  | 200 |  |  |  | IPR |  | E | C | EC13 | 1221 | de | LND |  | 1206C15 |
| EC45122105 |  | CA12 Catalyst Bldg - Building Layout drwgs AFC |  | 154d | 2010-01-18 A | 2010-08-25 A | AD2230, EC131221 FF, HEC45B FF, EC48100, EC461221 SS, EC441221, P3C0BD FS+10d | 100% |  | EC45122105 | EC45122105 | 87A |  | 12 |  | 200 |  |  | E | IPR |  | E | C | EC45 | 1221 | ar | LND |  | 1206C13 |
| EC461221 |  | CA12 Catalyst Bldg - Civil Static Calc Bldg |  | 175d | 2010-01-18 A | 2010-09-23 A | EC261201 SS+15d, EC441221, P3C0BD FS+10d | 100% |  | EC461221 | EC461221 | 87A |  | 12 |  | 200 |  |  |  | IPR |  | E | C | EC46 | 1221 | de | LND |  | 1206C14 |
| EC151221 |  | CA12 Catalyst Bldg - Piling drwgs AFC |  | 43d | 2010-02-08 A | 2010-04-09 A | EC131221 SS+10d, EC461221 SS+15d | 100% |  | EC151221 | EC151221 | 87A |  | 12 |  | 200 |  |  |  | IPR |  | E | C | EC15 | 1221 | PI | LND |  | 1206C16 |
| EC48122103 |  | CA12 Catalyst Bldg - Formw/Reinf drwgs Found. AFC |  | 96d | 2010-02-22 A | 2010-07-09 A | EC461221 SS+19d, EC28120110 SS, HEC48B FF, EC151221 SS+10d | 100% |  | EC48122103 | EC48122103 | 87A |  | 12 |  | 200 | 200 |  | E | IPR |  | E | C | EC48 | 1221 | ar | LND |  | 1206C21 |
| EC281221 |  | CA12 Catalyst Bldg - Formw/Reinf drwgs EqptFdtn AFC |  | 73d | 2010-03-25 A | 2010-07-09 A | EC48122105 SS, HEC28 FF | 100% |  | EC281221 | EC281221 | 87A |  | 12 |  | 200 |  |  |  | IPR |  | E | C | EC28 | 1221 | cq | LND |  |  |
| EC48122105 |  | CA12 Catalyst Bldg - Formw/Reinf drwgs GF +0,00 AFC |  | 108d | 2010-03-25 A | 2010-08-27 A | EC461221 SS+20d, HEC48S FF, EC48122103 FF+5d, EH241221 FF | 100% |  | EC48122105 | EC48122105 | 87A |  | 12 |  | 200 | 200 |  | E | IPR |  | E | C | EC48 | 1221 | ar | LND |  | 1206C22 |
| EC48122110 |  | CA12 Catalyst Bldg - Formw/Reinforce drwgs +6,00 AFC |  | 158d | 2010-03-25 A | 2010-11-05 A | EC48122105 FF+20d, EH241221 FF | 100% |  | EC48122110 | EC48122110 | 87A |  | 12 |  | 200 | 200 |  | E | IPR |  | E | C | EC48 | 1221 | ar | LND |  | 1206C23 |
| EC48122115 |  | CA12 Catalyst Bldg - Formw/Reinforce drwgs+13,70 AFC |  | 157d | 2010-04-07 A | 2010-11-15 A | EC48122110 FF+6d | 100% |  | EC48122115 | EC48122115 | 87A |  | 12 |  | 200 | 200 |  | E | IPR |  | E | C | EC48 | 1221 | ar | LND |  | 1206C24 |
| EC701221 |  | CA12 Catalyst Bldg - Structural Steel KM drwgs |  | 223d | 2010-04-15 A | 2011-02-28 A | EC45122105 SS+20d, EC48122110 FF | 100% |  | EC701221 | EC701221 | 87A | N02R | 12 | N02R | 200 |  |  |  | IPR |  | E | C | EC70 | 1221 | de | LND |  | 1206N51 |
| EC501221 |  | CA12 Catalyst Bldg - Architec Detail drwgs Bldg AFC |  | 192d | 2010-04-22 A | 2011-01-21 A | HEC50 FF, EC281221 SS+15d | 100% |  | EC501221 | EC501221 | 87A |  | 12 |  | 200 | 200 |  | E | IPR |  | E | C | EC50 | 1221 | ar | LND |  | 1206C41 |
| EC48122120 |  | CA12 Catalyst Bldg - Formw/Reinforce drwgs Roof AFC |  | 142d | 2010-04-29 A | 2010-11-16 A | EC48122115 FF | 100% |  | EC48122120 | EC48122120 | 87A |  | 12 |  | 200 | 200 |  | E | IPR |  | E | C | EC48 | 1221 | ar | LND |  | 1206C25 |
| EC45122110 |  | CA12 Catalyst Bldg - Building Layout drwgs IFC | milestone | 0d | 2010-07-20 A | 2010-07-20 A | EC45122105 FF-14d | 100% |  | EC45122110 | EC45122110 | 87A |  | 12 |  | 200 |  |  | E | IPR |  | E | C | EC45 | 1221 | ar | LND |  |  |

Notes:
- EC421221: P3 Activity Log Info: fixed Layout
- EC441221: P3 Activity Log Info: incl. PMT approval
- EC221221: P3 Activity Log Info: TKB-B Keyplan to Subcontractor
- EC45122105: P3 Activity Log Info: incl. PMT approval
- EC45122110: P3 Activity Log Info: incl. PMT approval

| ID | WBS | Activity | Type | Duration | Start | Finish | Predecessors | Complete | Planned start | Planned finish | Resources | UDF_SAVE ACTID | UDF_SAVE ACT ID | Department | Type of Work | Constr. Area | Inquiry/Order No | PMT-Area | PMT-Respons. | WBS Phase | WBS Discipline | WBS Type of Work | WBS Objects | IMS | UPT | PMT-Phase | PMT-Schedule Org | PMT-Discipline | TB26 Ressource Budget | Pro Unit/DocCode |
| --- | --- | --- | --- | --- | --- | --- | --- | --- | --- | --- | --- | --- | --- | --- | --- | --- | --- | --- | --- | --- | --- | --- | --- | --- | --- | --- | --- | --- | --- | --- |
|  | N | **N Structural Steel** |  |  | 2011-03-01 | 2011-04-04 |  |  |  |  |  |  |  |  |  |  |  |  |  |  |  |  |  |  |  |  |  |  |  |  |
| EN271221 |  | CA12 Catalyst Bldg SK1206 - Check KM drwgs |  | 5d | 2011-03-01 A | 2011-03-07 A | EC701221 | 100% |  |  |  | EN271221 | EN271221 | 87B | N02R | 12 | N02R | 200 | LEI | E | N | EN27 | 1221 | de | LND |  |  |  |  |  |
| EN281221 |  | CA12 Catalyst Bldg SK1206 - Shop dwgs(KMD) by Vendor |  | 20d | 2011-03-08 A | 2011-04-04 A | EN271221 | 100% |  |  |  | EN281221 | EN281221 | 87B | N02R | 12 | N02R | 200 | Chel | E | N | EN28 | 1221 | de | LND | E |  |  |  |  |
|  | H | **H HVAC** |  |  | 2008-11-24 | 2010-09-03 |  |  |  |  |  |  |  |  |  |  |  |  |  |  |  |  |  |  |  |  |  |  |  |  |
| EH201221 |  | CA12 Catalyst Bldg - HVAC&Plumbing / Feed/Basic |  | 165d | 2008-11-24 A | 2009-07-24 A | AD2230 FF+20d | 100% |  |  |  | EH201221 | EH201221 | 87C |  | 12 |  | 200 | LND | E | H | EH20 | 1221 | OTH | LND | E | 200 | 035 |  |  |
| EH30122105 |  | CA12 Catalyst Bldg - HVAC Layouts Dwgs AFC |  | 152d | 2009-12-22 A | 2010-08-02 A | EH201221, HEH30 FF, P3C0BD FS+5d | 100% |  |  | TKB-H [480 h] | EH30122105 | EH30122105 | 87C |  | 12 |  | 200 | IPR | E | H | EH30 | 1221 | OTH | LND | E | 200 | 035 | 480,00 | 1206H23 |
| EH40122105 |  | CA12 Catalyst Bldg- HVAC Calculations&Flow Diagrams |  | 151d | 2009-12-22 A | 2010-07-30 A | EH30122105 SS | 100% |  |  | TKB-H [320 h] | EH40122105 | EH40122105 | 87C |  | 12 |  | 200 | IPR | E | H | EH40 | 1221 | OTH | LND | E | 200 | 035 | 320,00 | 1206H22 |
| EH071221 |  | CA12 Catalyst Bldg - Issue of Dwgs&Doc's by RDI | level of effort | 97d | 2010-03-12 A | 2010-08-02 A | EH30122105 SS+55d, EH30122105 FF, EH40122110 FF | 100% | 2010-03-15 | 2010-08-02 | TKB-H [3544 h] | EH071221 | EH071221 | 87C |  | 12 |  | 200 | IPR | E | H | EH30 | 1221 | OTH | LND | E | 200 | 035 | 3544,00 |  |
| EH40122110 |  | CA12 Catalyst Bldg - HVAC Calc./Diagrams IFC | milestone | 0d | 2010-03-26 A | 2010-03-26 A | EH40122105 FF-15d | 100% |  |  |  | EH40122110 | EH40122110 | 87C |  | 12 |  | 200 | IPR | E | H | EH40 | 1221 | OTH | LND | E | 200 | 035 |  |  |
| EH30122115 |  | CA12 Catalyst Bldg - Review HVAC Layout Dwgs |  | 108d | 2010-04-01 A | 2010-09-03 A | EH30122110 | 100% |  |  | TKB-H [480 h] | EH30122115 | EH30122115 | 87C |  | 12 |  | 200 | LND | E | H | EH30 | 1221 | OTH | LND | E | 200 | 035 | 480,00 |  |
| EH30122110 |  | CA12 Catalyst Bldg - HVAC Layouts Dwgs IFC | milestone | 0d | 2010-05-11 A | 2010-05-11 A | EH30122105 FF-10d | 100% |  |  |  | EH30122110 | EH30122110 | 87C |  | 12 |  | 200 | IPR | E | H | EH30 | 1221 | OTH | LND | E | 200 | 035 |  |  |
| EH051221 |  | CA12 Catalyst Bldg -Final Loads f.Civil/StrSteel | milestone | 0d | 2010-06-28 A | 2010-06-28 A | EH30122105 FF-10d, E3H0150 SF, HEH12 FF | 100% |  |  |  | EH051221 | EH051221 | 87C |  | 12 |  | 200 | IPR | E | H | EH12 | 1221 | OTH | LND |  |  |  |  |  |
| EH241221 |  | CA12 Catalyst Bldg - Wall&Floor opening details | milestone | 0d | 2010-06-28 A | 2010-06-28 A | HEH24 FF, EH051221 FF, E3H0150 SF | 100% |  |  |  | EH241221 | EH241221 | 87C |  | 12 |  | 200 | IPR | E | H | EH24 | 1221 | OTH | LND | E | 200 | 035 |  | 1206H21 |
|  | B | **B Mechanical - Stationary Equipment** |  |  | 2009-02-18 | 2009-02-18 |  |  |  |  |  |  |  |  |  |  |  |  |  |  |  |  |  |  |  |  |  |  |  |  |
| EB051221 |  | CA12 Calalyst Bldg - Final Loads for Civil | milestone | 0d | 2009-02-18 A | 2009-02-18 A | E3A0310 FF, E3A0110 FF, E3A1320 SF | 100% |  |  |  | EB051221 | EB051221 | 869 |  | 12 |  | 200 | LND | E | B | EB05 | 1221 | 3 | LND |  |  |  |  |  |
|  | M | **M Mechanical - Rotating Equipment** |  |  | 2009-01-03 | 2009-01-03 |  |  |  |  |  |  |  |  |  |  |  |  |  |  |  |  |  |  |  |  |  |  |  |  |
| EM051221 |  | CA12 Calalyst Bldg - Final Loads for Civil | milestone | 0d | 2009-01-03 A | 2009-01-03 A | E3M0740, E3M1020 FF, E3M0820 FF | 100% |  |  |  | EM051221 | EM051221 | 867 |  | 12 |  | 200 | LND | E | M | EM05 | 1221 | I | LND |  |  |  |  |  |
|  | R | **R Piping** |  |  | 2008-04-01 | 2011-02-04 |  |  |  |  |  |  |  |  |  |  |  |  |  |  |  |  |  |  |  |  |  |  |  |  |
| ER151221 |  | CA12 Catalyst Bldg - Conceptual Piping |  | 169d | 2008-04-01 A | 2008-11-28 A | F2760 | 100% |  |  |  | ER151221 | ER151221 | 876 |  | 12 |  | 200 | LND | E | R | ER15 | 1221 | PL | LND |  |  |  |  |  |
| ER301221 |  | CA12 Catalyst Bldg - CAD Model Piping / Eqpt |  | 517d | 2008-07-01 A | 2010-07-23 A | ER391221 FF+10d, HER30 FF, ER151221 SS | 100% |  |  |  | ER301221 | ER301221 | 876 |  | 12 |  | 200 | LNI | E | R | ER30 | 1221 | PL | LND |  |  |  |  |  |
| ER161221 |  | CA12 Catalyst Bldg - prel Loads for Civil |  | 20d | 2009-01-05 A | 2009-01-30 A | ER151221 FF | 100% |  |  |  | ER161221 | ER161221 | 876 |  | 12 |  | 200 | LND | E | R | ER16 | 1221 | PL | LND |  |  |  |  |  |
| ER361221 |  | CA12 Catalyst Bldg - CAD Model Review 60% |  | 12d | 2009-11-02 A | 2009-11-17 A | F4030 SS | 100% |  |  |  | ER361221 | ER361221 | 876 |  | 12 |  | 200 | LND | E | R | ER36 | 1221 | 2 | LND |  |  |  |  |  |
| ER421221 |  | CA12 Catalyst Bldg - Stress Calculation |  | 98d | 2009-11-16 A | 2010-04-09 A | HER42 FF, ER361221 | 100% |  |  |  | ER421221 | ER421221 | 872 |  | 12 |  | 200 | LND | E | R | ER42 | 1221 | PL | LND |  |  |  |  |  |
| ER191221 |  | CA12 Catalyst Bldg - Final Loads for Civil | milestone | 0d | 2009-12-22 A | 2009-12-22 A | HER19 FF, ER161221 FF, EC461221 FF-10d, F4030 FF | 100% |  |  |  | ER191221 | ER191221 | 876 |  | 12 |  | 200 | LNI | E | R | ER19 | 1221 | PL | LND |  |  |  |  |  |
| ER391221 |  | CA12 Catalyst Bldg - CAD Model Review 90% |  | 10d | 2010-06-28 A | 2010-07-09 A | F4460 FF, HER39 FF | 100% |  |  |  | ER391221 | ER391221 | 876 |  | 12 |  | 200 | LND | E | R | ER39 | 1221 | 3 | LND |  |  |  |  |  |
| ER451221 |  | CA12 Catalyst Bldg - Piping Isometrics |  | 89d | 2010-08-16 A | 2010-12-17 A | ER421221, ER301221 FF+20d, ER391221 FS+15d | 100% |  |  |  | ER451221 | ER451221 | 876 |  | 12 |  | 200 | LEI | E | R | ER45 | 1221 | 5 | LND |  |  |  |  |  |
| ER491221 |  | CA12 Catalyst Bldg - Design Check/ Rel.Isos&BOM |  | 102d | 2010-09-13 A | 2011-02-04 A | ER451221 SS+20d, HER49 FF | 100% |  |  |  | ER491221 | ER491221 | 876 |  | 12 |  | 200 | LEI | E | R | ER49 | 1221 | 5 | LND |  |  |  |  |  |

| ID | WBS | Activity | Type | Duration | Start | Finish | Predecessors | Complete | UDF_CONTRACT START DATE | UDF_CONTRACT FINISH DATE | UDF_CONTRACT ITEM | UDF_SAVE ACTID | UDF_SAVE ACT ID | Department | Constr. Area | PMT-Phase | PMT-Respons. | WBS Phase | WBS Discipline | WBS Type of Work | WBS Objects | IMS | UPT | Pro Unit/DocCode | PMT-Area | PMT-Schedule Org | Type of Work | Inquiry/Order No |
| --- | --- | --- | --- | --- | --- | --- | --- | --- | --- | --- | --- | --- | --- | --- | --- | --- | --- | --- | --- | --- | --- | --- | --- | --- | --- | --- | --- | --- |
|  | E | **E Electrical** |  |  | 2008-10-06 | 2010-07-30 |  |  |  |  |  |  |  |  |  |  |  |  |  |  |  |  |  |  |  |  |  |  |
| EE46122105 |  | CA12 Catalyst Bldg -prelimLoads f.Civil/StrSteel |  | 15d | 2008-10-06 A | 2008-10-24 A | F3060 FF | 100% | 2011-05-10 | 2011-12-10 | E-16-07-03 | EE46122105 | EE46122105 | 874 | 12 | E | LND | E | E | EE11 | 1221 | E | LND |  |  |  |  |  |
| EE901221 |  | CA12 Catalyst Bldg - Earthing Details |  | 30d | 2009-06-22 A | 2009-07-31 A | HEE90 FF, EE901201 | 100% | 2011-05-10 | 2011-12-10 | E-16-07-03 | EE901221 | EE901221 | 874 | 12 | E | LND | E | E | EE90 | 1221 | E | LND |  |  |  |  |  |
| EE46122108 |  | CA12 Catalyst Bldg -Final Loads f.Civil/StrSteel |  | 20d | 2009-09-24 A | 2009-10-21 A | EE46122105 | 100% | 2011-05-10 | 2011-12-10 | E-16-07-03 | EE46122108 | EE46122108 | 874 | 12 | E | LEI | E | E | EE12 | 1221 | E | LND |  |  |  |  |  |
| EE46122110 |  | CA12 Catalyst Bldg - El. CableTray Layout Pl. / LOP's 1st Issue |  | 162d | 2009-12-07 A | 2010-07-30 A | HEE46 FF, EE460000, F4030 FF+75d | 100% | 2011-05-10 | 2011-12-10 | E-16-07-03 | EE46122110 | EE46122110 | 874 | 12 | E | LEI | E | E | EE46 | 1221 | E | LND |  |  |  |  |  |
| EE561221 |  | CA12 Catalyst Bldg - Cable Pulling Details |  | 159d | 2009-12-10 A | 2010-07-30 A | EE500130, EE46122110 FF | 100% | 2011-05-10 | 2011-12-10 | E-16-07-03 | EE561221 | EE561221 | 874 | 12 | E | LEI | E | E | EE56 | 1221 | E | LND |  |  |  |  |  |
| EE761221 |  | CA12 Catalyst Bldg - Layout Plan Light.& Sockets 1st Issue |  | 108d | 2010-01-26 A | 2010-06-30 A | EE000180, HEE76 FF, EC501221 SF+10d | 100% | 2011-05-10 | 2011-12-10 | E-16-07-03 | EE761221 | EE761221 | 874 | 12 | E | LEI | E | E | EE76 | 1221 | E | LND |  |  |  |  |  |
|  | J | **J Instrumentation** |  |  | 2008-10-06 | 2010-11-26 |  |  |  |  |  |  |  |  |  |  |  |  |  |  |  |  |  |  |  |  |  |  |
| EJ46122105 |  | CA12 Catalyst Bldg -prelimLoads f.Civil/StrSteel |  | 15d | 2008-10-06 A | 2008-10-24 A | F3060 FF | 100% |  |  |  | EJ46122105 | EJ46122105 | 86E | 12 | E | LND | E | J | EJ11 | 1221 | I | LND | 999 |  |  |  |  |
| EJ46122108 |  | CA12 Catalyst Bldg -Final Loads f.Civil/StrSteel |  | 10d | 2010-01-04 A | 2010-01-15 A | EJ46122105, HEJ12 FF | 100% |  |  |  | EJ46122108 | EJ46122108 | 86E | 12 | E | LEI | E | J | EJ12 | 1221 | I | LND | 999 |  |  |  |  |
| EJ361221 |  | CA12 Catalyst Bldg - Hook-Up drwgs 1st Issue |  | 90d | 2010-02-03 A | 2010-06-14 A | F4030 FS+50d, HEJ36 FF, A1EJ0080 | 100% |  |  |  | EJ361221 | EJ361221 | 86E | 12 | C | LEI | E | J | EJ36 | 1221 | I | LND | 999 | 200 | 200 |  |  |
| EJ46122110 |  | CA12 Catalyst Bldg - Instr Cable Tray Layout Pl. 1st Issue |  | 106d | 2010-03-01 A | 2010-07-30 A | F4030 FF, F4460, EE46122110 FF, HEJ46 FF | 100% |  |  |  | EJ46122110 | EJ46122110 | 86E | 12 | E | LEI | E | J | EJ41 | 1221 | I | LND | 999 |  |  |  |  |
| EJ321221 |  | CA12 Catalyst Bldg - JB Location drwgs |  | 25d | 2010-07-12 A | 2010-08-13 A | F4460 FF+25d, F4030, HEJ37 FF | 100% |  |  |  | EJ321221 | EJ321221 | 86E | 12 | C | LEI | E | J | EJ37 | 1221 | I | LND | 999 | 200 | 200 |  |  |
| EJ801221 |  | CA12 Catalyst Bldg - Loop Diagrams |  | 70d | 2010-08-20 A | 2010-11-26 A | EJ800010, HEJ80 FF, A1EJ0040 SF | 100% |  |  |  | EJ801221 | EJ801221 | 86E | 12 | E | LEI | E | J | EJ80 | 1221 | I | LND | 999 |  |  |  |  |
|  | 1222 | **1222 Teal Building Line 1 - CA12** |  |  | 2008-03-03 | 2011-03-28 |  |  |  |  |  |  |  |  |  |  |  |  |  |  |  |  |  |  |  |  |  |  |
|  | 0B | **0B General Activities** |  |  | 2009-01-03 | 2009-01-03 |  |  |  |  |  |  |  |  |  |  |  |  |  |  |  |  |  |  |  |  |  |  |
| E0201222 |  | CA12 Teal Bldg - freeze construction concept | milestone | 0d | 2009-01-03 A | 2009-01-03 A | F3600 | 100% |  |  |  | E0201222 | E0201222 | 87A | 12 | E |  | E | 0B | E020 | 1222 | INS | LND |  | 200 |  |  |  |
|  | C | **C Civil** |  |  | 2008-03-03 | 2011-02-18 |  |  |  |  |  |  |  |  |  |  |  |  |  |  |  |  |  |  |  |  |  |  |
| EC421222 |  | CA12 Teal Bldg - Building Concept |  | 171d | 2008-03-03 A | 2008-11-04 A | F2760 | 100% |  |  |  | EC421222 | EC421222 | 87A | 12 |  | LND | E | C | EC42 | 1222 | cq | LND |  | 200 |  |  |  |
| EC241222 |  | CA12 Teal Bldg - Foundation Data Sheets Eqpt |  | 128d | 2009-02-25 A | 2009-08-28 A | EM051222, ER161222, EB051222 | 100% |  |  |  | EC241222 | EC241222 | 87A | 12 |  | LND | E | C | EC24 | 1222 | de | LND |  | 200 |  |  |  |
| EC221222 |  | CA12 Teal Bldg - Civil Foundation Loads Bldg |  | 20d | 2009-12-15 A | 2010-01-15 A | EE46122208, EC241222 FF, EJ46122208 FF, ER161222 | 100% |  |  |  | EC221222 | EC221222 | 87A | 12 | E | LND | E | C | EC22 | 1222 | de | LND |  | 200 | 200 |  |  |
| EC441222 |  | CA12 Teal Bldg - Building Layout drwgs IFD |  | 15d | 2009-12-22 A | 2010-01-15 A | EC221222 FF, AD2230 FF+30d, E0201222, EC421222 | 100% |  |  |  | EC441222 | EC441222 | 87A | 12 |  | LND | E | C | EC44 | 1222 | de | LND | 1202C01 | 200 |  |  |  |
| EC131222 |  | CA12 Teal Bldg - Fire Safety Survey Report |  | 188d | 2010-01-18 A | 2010-10-12 A | EC461222 SS | 100% |  |  |  | EC131222 | EC131222 | 87A | 12 |  | IPR | E | C | EC13 | 1222 | de | LND | 1202C15 | 200 |  |  |  |
| EC45122205 |  | CA12 Teal Bldg - Building Layout drwgs AFC |  | 142d | 2010-01-18 A | 2010-08-09 A | EC441222, P3C0BD FS+15d, EC131222 FF, EH241222 FF, IMS-E-000170 FF, HEC45B FF, AD2230, EC48100, EC461222 SS | 100% |  |  |  | EC45122205 | EC45122205 | 87A | 12 | E | IPR | E | C | EC45 | 1222 | ar | LND | 1202C13 | 200 |  |  |  |
| EC461222 |  | CA12 Teal Bldg - Civil Static Calc Bldg |  | 158d | 2010-01-18 A | 2010-08-31 A | EC261201 SS+10d, EC441222, P3C0BD FS+15d | 100% |  |  |  | EC461222 | EC461222 | 87A | 12 |  | IPR | E | C | EC46 | 1222 | de | LND | 1202C14 | 200 |  |  |  |
| EC151222 |  | CA12 Teal Bldg - Piling drwgs AFC |  | 48d | 2010-02-01 A | 2010-04-09 A | EC131222 SS+10d, EC461222 SS+10d | 100% |  |  |  | EC151222 | EC151222 | 87A | 12 |  | IPR | E | C | EC15 | 1222 | PI | LND | 1202C16 | 200 |  |  |  |
| EC48122203 |  | CA12 Teal Bldg - Formw/Reinf. drwgs Bldg Found. AFC |  | 107d | 2010-02-19 A | 2010-07-23 A | HEC48B FF, EC461222 SS+20d, EC151222 SS+14d | 100% |  |  |  | EC48122203 | EC48122203 | 87A | 12 | E | IPR | E | C | EC48 | 1222 | ar | LND | 1202C21 | 200 | 200 |  |  |
| EC48122205 |  | CA12 Teal Bldg - Formw/Reinf drwgs Bldg GF +0,00 AFC |  | 119d | 2010-03-05 A | 2010-08-24 A | EC48122203 SS+10d, HEC48S FF | 100% |  |  |  | EC48122205 | EC48122205 | 87A | 12 | E | IPR | E | C | EC48 | 1222 | ar | LND | 1202C22 | 200 | 200 |  |  |
| EC281222 |  | CA12 Teal Bldg - Formw/Reinf drwgs EqptFdtn AFC |  | 103d | 2010-03-29 A | 2010-08-24 A | HEC28 FF, EC48122203 FF | 100% |  |  |  | EC281222 | EC281222 | 87A | 12 |  | IPR | E | C | EC28 | 1222 | cq | LND |  | 200 |  |  |  |
| EC701222 |  | CA12 Teal Bldg SK1202 - Structural Steel KM drwgs |  | 228d | 2010-03-29 A | 2011-02-18 A | EC48122205 SS+16d, EC45122205 SS+30d | 100% |  |  |  | EC701222 | EC701222 | 87A | 12 |  | IPR | E | C | EC70 | 1222 | de | LND | 1202N51 | 200 |  | N02P | N02P |
| EC501222 |  | CA12 Teal Bldg - Architec.Detail drwgs Bldg AFC |  | 192d | 2010-04-22 A | 2011-01-21 A | EC120 FF, EC281222 FF+5d, HEC50 FF | 100% |  |  |  | EC501222 | EC501222 | 87A | 12 | E | IPR | E | C | EC50 | 1222 | ar | LND | 1202C41 | 200 | 200 |  |  |
| EC45122210 |  | CA12 Teal Bldg - Building Layout drwgs IFC | milestone | 0d | 2010-05-28 A | 2010-05-28 A | EC45122205 FF-15d | 100% |  |  |  | EC45122210 | EC45122210 | 87A | 12 | E | IPR | E | C | EC45 | 1222 | ar | LND |  | 200 |  |  |  |

Notes:
- EC421222: P3 Activity Log Info: fixed Layout
- EC221222: P3 Activity Log Info: TKB-B Keyplan to Subcontractor
- EC441222: P3 Activity Log Info: incl. PMT approval
- EC45122205: P3 Activity Log Info: incl. PMT approval
- EC45122210: P3 Activity Log Info: incl. PMT approval

| ID | WBS | Activity | Type | Duration | Start | Finish | Predecessors | Complete | Resources | UDF_SAVE ACTID | UDF_SAVE ACT ID | Department | Type of Work | Constr. Area | Inquiry/Order No | PMT-Area | PMT-Respons. | WBS Phase | WBS Discipline | WBS Type of Work | WBS Objects | IMS | UPT | PMT-Phase | PMT-Schedule Org | PMT-Discipline | TB26 Ressource Budget | Pro Unit/DocCode |
| --- | --- | --- | --- | --- | --- | --- | --- | --- | --- | --- | --- | --- | --- | --- | --- | --- | --- | --- | --- | --- | --- | --- | --- | --- | --- | --- | --- | --- |
|  | N | **N Structural Steel** |  |  | 2011-02-14 | 2011-03-28 |  |  |  |  |  |  |  |  |  |  |  |  |  |  |  |  |  |  |  |  |  |  |
| EN271222 |  | CA12 Teal Bldg SK1202 - Check KM drwgs |  | 16d | 2011-02-14 A | 2011-03-07 A | EC701222 | 100% |  | EN271222 | EN271222 | 87B | N02P | 12 | N02P | 200 | LEI | E | N | EN27 | 1222 | de | LND |  |  |  |  |  |
| EN281222 |  | CA12 Teal Bldg SK1202 - Shop dwgs(KMD) by Vendor |  | 15d | 2011-03-08 A | 2011-03-28 A | EN271222 | 100% |  | EN281222 | EN281222 | 87B | N02P | 12 | N02P | 200 | Chel | E | N | EN28 | 1222 | de | LND | E |  |  |  |  |
|  | H | **H HVAC** |  |  | 2008-11-24 | 2010-07-09 |  |  |  |  |  |  |  |  |  |  |  |  |  |  |  |  |  |  |  |  |  |  |
| EH201222 |  | CA12 Teal Bldg - HVAC&Plumbing / Feed/Basic |  | 165d | 2008-11-24 A | 2009-07-24 A | AD2230 FF+20d | 100% |  | EH201222 | EH201222 | 87C |  | 12 |  | 200 | LND | E | H | EH20 | 1222 | OTH | LND | E | 200 | 035 |  |  |
| EH30122205 |  | CA12 Teal Bldg - HVAC Layouts Dwgs AFC |  | 119d | 2010-01-11 A | 2010-06-30 A | EH201221, HEH30 FF, P3C0BD FS+15d | 100% | TKB-H [360 h] | EH30122205 | EH30122205 | 87C |  | 12 |  | 200 | IPR | E | H | EH30 | 1222 | OTH | LND | E | 200 | 035 | 360,00 | 1202H23 |
| EH40122205 |  | CA12 Teal Bldg- HVAC Calculations&Flow Diagrams |  | 119d | 2010-01-11 A | 2010-06-30 A | EH30122205 SS | 100% | TKB-H [240 h] | EH40122205 | EH40122205 | 87C |  | 12 |  | 200 | IPR | E | H | EH40 | 1222 | OTH | LND | E | 200 | 035 | 240,00 | 1202H22 |
| EH071222 |  | CA12 Teal Bldg - Issue of Dwgs&Doc's by RDI | level of effort | 69d | 2010-03-22 A | 2010-06-30 A | EH30122205 SS+50d, EH40122210 FF, EH30122205 FF | 100% | TKB-H [672 h] | EH071222 | EH071222 | 87C |  | 12 |  | 200 | IPR | E | H | EH30 | 1222 | OTH | LND | E | 200 | 035 | 672,00 |  |
| EH40122210 |  | CA12 Teal Bldg - HVAC Calc./Diagrams IFC | milestone | 0d | 2010-03-26 A | 2010-03-26 A | EH40122205 FF-15d | 100% |  | EH40122210 | EH40122210 | 87C |  | 12 |  | 200 | IPR | E | H | EH40 | 1222 | OTH | LND | E | 200 | 035 |  |  |
| EH30122215 |  | CA12 Teal Bldg - Review HVAC Layout Dwgs |  | 68d | 2010-04-01 A | 2010-07-09 A | EH30122210 | 100% | TKB-H [360 h] | EH30122215 | EH30122215 | 87C |  | 12 |  | 200 | LND | E | H | EH30 | 1222 | OTH | LND | E | 200 | 035 | 360,00 |  |
| EH30122210 |  | CA12 Teal Bldg - HVAC Layouts Dwgs IFC | milestone | 0d | 2010-05-11 A | 2010-05-11 A | EH30122205 FF-6d | 100% |  | EH30122210 | EH30122210 | 87C |  | 12 |  | 200 | IPR | E | H | EH30 | 1222 | OTH | LND | E | 200 | 035 |  |  |
| EH051222 |  | CA12 Teal Bldg - Final Loads f.Civil/StrSteel | milestone | 0d | 2010-05-31 A | 2010-05-31 A | EH30122205 FF-20d, E3H0150 SF | 100% |  | EH051222 | EH051222 | 87C |  | 12 |  | 200 | IPR | E | H | EH12 | 1222 | OTH | LND |  |  |  |  |  |
| EH241222 |  | CA12 Teal Bldg - Wall&Floor opening details | milestone | 0d | 2010-05-31 A | 2010-05-31 A | EH051222 FF, HEH24 FF, E3H0150 SF | 100% |  | EH241222 | EH241222 | 87C |  | 12 |  | 200 | IPR | E | H | EH24 | 1222 | OTH | LND | E | 200 | 035 |  | 1202H21 |
|  | B | **B Mechanical - Stationary Equipment** |  |  | 2009-04-01 | 2009-04-01 |  |  |  |  |  |  |  |  |  |  |  |  |  |  |  |  |  |  |  |  |  |  |
| EB051222 |  | CA12 Teal Bldg - Final Loads for Civil | milestone | 0d | 2009-04-01 A | 2009-04-01 A | E3A1320 SF, E3A1120 SF | 100% |  | EB051222 | EB051222 | 869 |  | 12 |  | 200 | LND | E | B | EB05 | 1222 | 3 | LND |  |  |  |  |  |
|  | M | **M Mechanical - Rotating Equipment** |  |  | 2009-01-03 | 2009-01-03 |  |  |  |  |  |  |  |  |  |  |  |  |  |  |  |  |  |  |  |  |  |  |
| EM051222 |  | CA12 Teal Bldg - Final Loads for Civil | milestone | 0d | 2009-01-03 A | 2009-01-03 A | E3M0820 FF | 100% |  | EM051222 | EM051222 | 867 |  | 12 |  | 200 | LND | E | M | EM05 | 1222 | I | LND |  |  |  |  |  |
|  | R | **R Piping** |  |  | 2008-04-01 | 2011-02-04 |  |  |  |  |  |  |  |  |  |  |  |  |  |  |  |  |  |  |  |  |  |  |
| ER151222 |  | CA12 Teal Bldg - Conceptual Piping |  | 169d | 2008-04-01 A | 2008-11-28 A | F2760 | 100% |  | ER151222 | ER151222 | 876 |  | 12 |  | 200 | LND | E | R | ER15 | 1222 | PL | LND |  |  |  |  |  |
| ER301222 |  | CA12 Teal Bldg - CAD Model Piping / Eqpt |  | 517d | 2008-07-01 A | 2010-07-23 A | ER151222 SS, ER391222 FF+10d | 100% |  | ER301222 | ER301222 | 876 |  | 12 |  | 200 | LNI | E | R | ER30 | 1222 | PL | LND |  |  |  |  |  |
| ER161222 |  | CA12 Teal Bldg - prel Loads for Civil |  | 20d | 2009-01-05 A | 2009-01-30 A | ER151222 FF | 100% |  | ER161222 | ER161222 | 876 |  | 12 |  | 200 | LND | E | R | ER16 | 1222 | PL | LND |  |  |  |  |  |
| ER361222 |  | CA12 Teal Bldg - CAD Model Review 60% |  | 12d | 2009-11-02 A | 2009-11-17 A | F4030 SS | 100% |  | ER361222 | ER361222 | 876 |  | 12 |  | 200 | LND | E | R | ER36 | 1222 | 2 | LND |  |  |  |  |  |
| ER421222 |  | CA12 Teal Bldg - Stress Calculation |  | 98d | 2009-11-16 A | 2010-04-09 A | ER361222, HER42 FF | 100% |  | ER421222 | ER421222 | 872 |  | 12 |  | 200 | LND | E | R | ER42 | 1222 | PL | LND |  |  |  |  |  |
| ER191222 |  | CA12 Teal Bldg - Final Loads for Civil | milestone | 0d | 2010-01-04 A | 2010-01-04 A | EC461222 SF-10d, HER19 FF, ER161222 FF, F4030 FF+5d | 100% |  | ER191222 | ER191222 | 876 |  | 12 |  | 200 | LNI | E | R | ER19 | 1222 | PL | LND |  |  |  |  |  |
| ER391222 |  | CA12 Teal Bldg - CAD Model Review 90% |  | 10d | 2010-06-28 A | 2010-07-09 A | HER39 FF, F4460 FF | 100% |  | ER391222 | ER391222 | 876 |  | 12 |  | 200 | LND | E | R | ER39 | 1222 | 3 | LND |  |  |  |  |  |
| ER451222 |  | CA12 Teal Bldg - Piping Isometrics |  | 104d | 2010-07-26 A | 2010-12-17 A | ER391222 FS+10d, ER421222, ER301222 FF+20d | 100% |  | ER451222 | ER451222 | 876 |  | 12 |  | 200 | LEI | E | R | ER45 | 1222 | 5 | LND |  |  |  |  |  |
| ER491222 |  | CA12 Teal Bldg - Design Check/ Rel.Isos&BOM |  | 110d | 2010-09-01 A | 2011-02-04 A | HER49 FF, HPR30 FF, ER451222 SS+20d | 100% |  | ER491222 | ER491222 | 876 |  | 12 |  | 200 | LEI | E | R | ER49 | 1222 | 5 | LND |  |  |  |  |  |

| ID | WBS | Activity | Type | Duration | Start | Finish | Predecessors | Complete | UDF_CONTRACT START DATE | UDF_CONTRACT FINISH DATE | UDF_CONTRACT ITEM | UDF_SAVE ACTID | UDF_SAVE ACT ID | Department | Constr. Area | PMT-Phase | PMT-Respons. | WBS Phase | WBS Discipline | WBS Type of Work | WBS Objects | IMS | UPT | Pro Unit/DocCode | PMT-Area | PMT-Schedule Org |
| --- | --- | --- | --- | --- | --- | --- | --- | --- | --- | --- | --- | --- | --- | --- | --- | --- | --- | --- | --- | --- | --- | --- | --- | --- | --- | --- |
|  | E | **E Electrical** |  |  | 2008-10-06 | 2010-07-30 |  |  |  |  |  |  |  |  |  |  |  |  |  |  |  |  |  |  |  |  |
| EE46122205 |  | CA12 Teal Bldg - prelim Loads f.Civil / StrSteel |  | 15d | 2008-10-06 A | 2008-10-24 A | F3060 FF | 100% | 2011-05-10 | 2011-12-10 | E-16-07-03 | EE46122205 | EE46122205 | 874 | 12 | E | LND | E | E | EE11 | 1222 | E | LND |  |  |  |
| EE901222 |  | CA12 Teal Bldg - Earthing Details |  | 30d | 2009-06-22 A | 2009-07-31 A | EE901201, HEE90 FF | 100% | 2011-05-10 | 2011-12-10 | E-16-07-03 | EE901222 | EE901222 | 874 | 12 | E | LND | E | E | EE90 | 1222 | E | LND |  |  |  |
| EE46122208 |  | CA12 Teal Bldg - Final Loads f.Civil / StrSteel |  | 20d | 2009-09-17 A | 2009-10-14 A | EE46122205 | 100% | 2011-05-10 | 2011-12-10 | E-16-07-03 | EE46122208 | EE46122208 | 874 | 12 | E | LEI | E | E | EE12 | 1222 | E | LND |  |  |  |
| EE46122210 |  | CA12 Teal Bldg -El. CableTray Layout Pl. / LOP's 1st Issue |  | 162d | 2009-12-07 A | 2010-07-30 A | F4030 FF+75d, HEE46 FF, EE460000 | 100% | 2011-05-10 | 2011-12-10 | E-16-07-03 | EE46122210 | EE46122210 | 874 | 12 | E | LEI | E | E | EE46 | 1222 | E | LND |  |  |  |
| EE561222 |  | CA12 Teal Bldg - Cable Pulling Details |  | 159d | 2009-12-10 A | 2010-07-30 A | EE500130, EE46122210 FF | 100% | 2011-05-10 | 2011-12-10 | E-16-07-03 | EE561222 | EE561222 | 874 | 12 | E | LEI | E | E | EE56 | 1222 | E | LND |  |  |  |
| EE761222 |  | CA12 Teal Bldg - Layout Plan Light.& Sockets 1st Issue |  | 108d | 2010-01-26 A | 2010-06-30 A | EE000180, HEE76 FF, EC501222 SF+10d | 100% | 2011-05-10 | 2011-12-10 | E-16-07-03 | EE761222 | EE761222 | 874 | 12 | E | LEI | E | E | EE76 | 1222 | E | LND |  |  |  |
|  | J | **J Instrumentation** |  |  | 2008-10-06 | 2010-11-26 |  |  |  |  |  |  |  |  |  |  |  |  |  |  |  |  |  |  |  |  |
| EJ46122205 |  | CA12 Teal Bldg - prelim Loads f.Civil / StrSteel |  | 15d | 2008-10-06 A | 2008-10-24 A | F3060 FF | 100% |  |  |  | EJ46122205 | EJ46122205 | 86E | 12 | E | LND | E | J | EJ11 | 1222 | I | LND | 999 |  |  |
| EJ46122208 |  | CA12 Teal Bldg - Final Loads f.Civil / StrSteel |  | 10d | 2010-01-04 A | 2010-01-15 A | HEJ12 FF, EJ46122205 | 100% |  |  |  | EJ46122208 | EJ46122208 | 86E | 12 | E | LEI | E | J | EJ12 | 1222 | I | LND | 999 |  |  |
| EJ361222 |  | CA12 Teal Bldg - Hook-Up drwgs 1st Issue |  | 90d | 2010-02-03 A | 2010-06-14 A | F4030 FS+50d, A1EJ0080, HEJ36 FF | 100% |  |  |  | EJ361222 | EJ361222 | 86E | 12 | C | LEI | E | J | EJ36 | 1222 | I | LND | 999 | 200 | 200 |
| EJ46122210 |  | CA12 Teal Bldg - Instr Cable Tray Layout Plan 1st Issue |  | 106d | 2010-03-01 A | 2010-07-30 A | EE46122210 FF, F4030 FF, F4460, HEJ46 FF | 100% |  |  |  | EJ46122210 | EJ46122210 | 86E | 12 | E | LEI | E | J | EJ41 | 1222 | I | LND | 999 |  |  |
| EJ321222 |  | CA12 Teal Bldg - JB Location drwgs |  | 25d | 2010-07-12 A | 2010-08-13 A | F4460 FF+25d, HEJ37 FF, F4030 | 100% |  |  |  | EJ321222 | EJ321222 | 86E | 12 | C | LEI | E | J | EJ37 | 1222 | I | LND | 999 | 200 | 200 |
| EJ801222 |  | CA12 Teal Bldg - Loop Diagrams |  | 70d | 2010-08-20 A | 2010-11-26 A | EJ800010, A1EJ0040 SF, HEJ80 FF | 100% |  |  |  | EJ801222 | EJ801222 | 86E | 12 | E | LEI | E | J | EJ80 | 1222 | I | LND | 999 |  |  |
|  | 1230 | **1230 Other Ground Based Eqpt - CA12** |  |  | 2008-04-01 | 2011-02-04 |  |  |  |  |  |  |  |  |  |  |  |  |  |  |  |  |  |  |  |  |
|  | C | **C Civil** |  |  | 2009-08-17 | 2010-07-16 |  |  |  |  |  |  |  |  |  |  |  |  |  |  |  |  |  |  |  |  |
| EC241230 |  | CA12 OthGrBasedEqpt - Layout Drwg / Fdtn Data Sheets Eqp IFD |  | 20d | 2009-08-17 A | 2009-09-11 A | ER161230, EB051230, EM051230 | 100% |  |  |  | EC241230 | EC241230 | 87A | 12 |  | LND | E | C | EC24 | 1230 | de | LND | 1210C01 | 200 |  |
| EC261230 |  | CA12 OthGrBasedEqpt - Civil Static Calc Fdtn |  | 96d | 2010-02-08 A | 2010-06-25 A | EC241230, P3C0BD FS+10d, EC261201 SS+30d | 100% |  |  |  | EC261230 | EC261230 | 87A | 12 |  | IPR | E | C | EC26 | 1230 | de | LND | 1210C14 | 200 |  |
| EC281230 |  | CA12 OthGrBasedEqpt - Formw/Reinf drwgs Fdtn AFC |  | 81d | 2010-03-22 A | 2010-07-16 A | EC28120410 FF, EC261230 SS+30d, HEC28 FF | 100% |  |  |  | EC281230 | EC281230 | 87A | 12 |  | IPR | E | C | EC28 | 1230 | cq | LND | 1210C21 | 200 |  |
|  | B | **B Mechanical - Stationary Equipment** |  |  | 2008-11-26 | 2008-11-26 |  |  |  |  |  |  |  |  |  |  |  |  |  |  |  |  |  |  |  |  |
| EB051230 |  | CA12 OthGrBasedEqpt - Final Loads for Civil | milestone | 0d | 2008-11-26 A | 2008-11-26 A | E3A0620 SF | 100% |  |  |  | EB051230 | EB051230 | 869 | 12 |  | LND | E | B | EB05 | 1230 | 3 | LND |  | 200 |  |
|  | M | **M Mechanical - Rotating Equipment** |  |  | 2008-10-11 | 2008-10-11 |  |  |  |  |  |  |  |  |  |  |  |  |  |  |  |  |  |  |  |  |
| EM051230 |  | CA12 OthGrBasedEqpt - Final Loads for Civil | milestone | 0d | 2008-10-11 A | 2008-10-11 A | E3M0640 | 100% |  |  |  | EM051230 | EM051230 | 867 | 12 |  | LND | E | M | EM05 | 1230 | I | LND |  | 200 |  |
|  | R | **R Piping** |  |  | 2008-04-01 | 2011-02-04 |  |  |  |  |  |  |  |  |  |  |  |  |  |  |  |  |  |  |  |  |
| ER151230 |  | CA12 OthGrBasedEqpt - Conceptual Piping |  | 169d | 2008-04-01 A | 2008-11-28 A | F2760 | 100% |  |  |  | ER151230 | ER151230 | 876 | 12 |  | LND | E | R | ER15 | 1230 | PL | LND |  | 200 |  |
| ER301230 |  | CA12 OthGrBasedEqpt - CAD Model Piping / Eqpt |  | 517d | 2008-07-01 A | 2010-07-23 A | ER391230 FF+10d, ER151230 SS | 100% |  |  |  | ER301230 | ER301230 | 876 | 12 |  | LNI | E | R | ER30 | 1230 | PL | LND |  | 200 |  |
| ER161230 |  | CA12 OthGrBasedEqpt - prel Loads for Civil |  | 20d | 2009-01-05 A | 2009-01-30 A | ER151230 FF | 100% |  |  |  | ER161230 | ER161230 | 876 | 12 |  | LND | E | R | ER16 | 1230 | PL | LND |  | 200 |  |
| ER361230 |  | CA12 OthGrBasedEqpt - CAD Model Review 60% |  | 12d | 2009-11-02 A | 2009-11-17 A | F4030 SS | 100% |  |  |  | ER361230 | ER361230 | 876 | 12 |  | LND | E | R | ER36 | 1230 | 2 | LND |  | 200 |  |
| ER421230 |  | CA12 OthGrBasedEqpt - Stress Calculation |  | 98d | 2009-11-16 A | 2010-04-09 A | ER361230 | 100% |  |  |  | ER421230 | ER421230 | 872 | 12 |  | LND | E | R | ER42 | 1230 | PL | LND |  | 200 |  |
| ER191230 |  | CA12 OthGrBasedEqpt - Final Loads for Civil | milestone | 0d | 2010-01-25 A | 2010-01-25 A | HER19 FF, EC261230 SF-10d, ER161230 FF, F4030 SF+20d | 100% |  |  |  | ER191230 | ER191230 | 876 | 12 |  | LNI | E | R | ER19 | 1230 | PL | LND |  | 200 |  |
| ER391230 |  | CA12 OthGrBasedEqpt - CAD Model Review 90% |  | 10d | 2010-06-28 A | 2010-07-09 A | F4460 FF | 100% |  |  |  | ER391230 | ER391230 | 876 | 12 |  | LND | E | R | ER39 | 1230 | 3 | LND |  | 200 |  |
| ER451230 |  | CA12 OthGrBasedEqpt - Piping Isometrics |  | 104d | 2010-07-26 A | 2010-12-17 A | ER421230, ER391230 FS+10d, ER301230 FF+20d | 100% |  |  |  | ER451230 | ER451230 | 876 | 12 |  | LEI | E | R | ER45 | 1230 | 5 | LND |  | 200 |  |
| ER491230 |  | CA12 OthGrBasedEqpt - DesignCheck/Rel.Isos&BOM |  | 110d | 2010-09-01 A | 2011-02-04 A | ER451230 SS+20d | 100% |  |  |  | ER491230 | ER491230 | 876 | 12 |  | LEI | E | R | ER49 | 1230 | 5 | LND |  | 200 |  |

| ID | WBS | Activity | Type | Duration | Start | Finish | Predecessors | Complete | Resources | Cost | Actual cost | UDF_CONTRACT START DATE | UDF_CONTRACT FINISH DATE | UDF_CONTRACT ITEM | UDF_SAVE ACTID | UDF_SAVE ACT ID | Department | Constr. Area | PMT-Phase | PMT-Respons. | WBS Phase | WBS Discipline | WBS Type of Work | WBS Objects | IMS | UPT | Pro Unit/DocCode | PMT-Area | PMT-Schedule Org | Type of Work | Inquiry/Order No | PMT-Discipline | PMT-Stage | Zeigen/n. Zeigen | PMT-Doc. Type | TB26 Ressource Budget |
| --- | --- | --- | --- | --- | --- | --- | --- | --- | --- | --- | --- | --- | --- | --- | --- | --- | --- | --- | --- | --- | --- | --- | --- | --- | --- | --- | --- | --- | --- | --- | --- | --- | --- | --- | --- | --- |
|  | E | **E Electrical** |  |  | 2009-05-07 | 2010-07-30 |  |  |  |  |  |  |  |  |  |  |  |  |  |  |  |  |  |  |  |  |  |  |  |  |  |  |  |  |  |  |
| EE901230 |  | CA12 OthGrBasedEqpt - Earthing Details |  | 30d | 2009-05-07 A | 2009-06-19 A | EE901201 SS | 100% |  |  |  | 2011-05-10 | 2011-12-10 | E-16-07-03 | EE901230 | EE901230 | 874 | 12 | E | LND | E | E | EE90 | 1230 | E | LND |  |  |  |  |  |  |  |  |  |  |
| EE46123010 |  | CA12 OthGrBasedEqpt - El. CableTray Layout Pl. / LOP's 1st Issue |  | 162d | 2009-12-07 A | 2010-07-30 A | F4030 FF+75d, EE460000 | 100% |  |  |  | 2011-05-10 | 2011-12-10 | E-16-07-03 | EE46123010 | EE46123010 | 874 | 12 | E | LEI | E | E | EE46 | 1230 | E | LND |  |  |  |  |  |  |  |  |  |  |
| EE561230 |  | CA12 OthGrBasedEqpt - Cable Pulling Details |  | 159d | 2009-12-10 A | 2010-07-30 A | EE46123010 FF, EE500130 | 100% |  |  |  | 2011-05-10 | 2011-12-10 | E-16-07-03 | EE561230 | EE561230 | 874 | 12 | E | LEI | E | E | EE56 | 1230 | E | LND |  |  |  |  |  |  |  |  |  |  |
|  | J | **J Instrumentation** |  |  | 2010-02-03 | 2010-11-26 |  |  |  |  |  |  |  |  |  |  |  |  |  |  |  |  |  |  |  |  |  |  |  |  |  |  |  |  |  |  |
| EJ361230 |  | CA12 OthGrBasedEqpt - Hook-Up drwgs 1st Issue |  | 90d | 2010-02-03 A | 2010-06-14 A | A1EJ0080, F4030 FS+50d | 100% |  |  |  |  |  |  | EJ361230 | EJ361230 | 86E | 12 | C | LEI | E | J | EJ36 | 1230 | I | LND | 999 | 200 | 200 |  |  |  |  |  |  |  |
| EJ46123010 |  | CA12 OthGrBasedEqpt - Instr CableTray Layout Pl. 1st Issue |  | 106d | 2010-03-01 A | 2010-07-30 A | F4030 FF, F4460, EE46123010 FF | 100% |  |  |  |  |  |  | EJ46123010 | EJ46123010 | 86E | 12 | E | LEI | E | J | EJ41 | 1230 | I | LND | 999 |  |  |  |  |  |  |  |  |  |
| EJ321230 |  | CA12 OthGrBasedEqpt - JB Location drwgs |  | 25d | 2010-07-12 A | 2010-08-13 A | F4460 FF+25d, F4030 | 100% |  |  |  |  |  |  | EJ321230 | EJ321230 | 86E | 12 | C | LEI | E | J | EJ37 | 1230 | I | LND | 999 | 200 | 200 |  |  |  |  |  |  |  |
| EJ801230 |  | CA12 OthGrBasedEqpt - Loop Diagrams |  | 70d | 2010-08-20 A | 2010-11-26 A | EJ800010, A1EJ0040 SF | 100% |  |  |  |  |  |  | EJ801230 | EJ801230 | 86E | 12 | E | LEI | E | J | EJ80 | 1230 | I | LND | 999 |  |  |  |  |  |  |  |  |  |
|  | 1232 | **1232 Recycle Gas Compressor - CA12** |  |  | 2008-03-07 | 2011-02-04 |  |  |  |  |  |  |  |  |  |  |  |  |  |  |  |  |  |  |  |  |  |  |  |  |  |  |  |  |  |  |
|  | C | **C Civil** |  |  | 2009-01-02 | 2010-09-30 |  |  |  |  |  |  |  |  |  |  |  |  |  |  |  |  |  |  |  |  |  |  |  |  |  |  |  |  |  |  |
| EC241232 |  | CA12 R.G.Compressor - Layout Drwg / Loads IFD |  | 20d | 2009-01-02 A | 2009-01-29 A | EM051232, ER161232 | 100% |  |  |  |  |  |  | EC241232 | EC241232 | 87A | 12 |  | LND | E | C | EC24 | 1232 | de | LND | 1211C01 | 200 |  |  |  |  |  |  |  |  |
| EC151232 |  | CA12 R.G.Compressor - Piling drwgs AFC |  | 50d | 2010-02-01 A | 2010-04-13 A | EC151201 FF, EC261232 SS | 100% |  |  |  |  |  |  | EC151232 | EC151232 | 87A | 12 |  | IPR | E | C | EC15 | 1232 | PI | LND | 1211C16 | 200 |  |  |  |  |  |  |  |  |
| EC261232 |  | CA12 R.G.Compressor - Civil Static Calc EqptFdtn |  | 170d | 2010-02-01 A | 2010-09-30 A | P3C0BD FS+10d, EC241232, EC461222 SS+10d | 100% |  |  |  |  |  |  | EC261232 | EC261232 | 87A | 12 |  | IPR | E | C | EC26 | 1232 | de | LND | 1211C14 | 200 |  |  |  |  |  |  |  |  |
| EC281232 |  | CA12 R.G.Compressor - Formw/Reinforce drwgs AFC |  | 106d | 2010-03-01 A | 2010-07-30 A | EC261232 SS+20d, EC151232 SS+15d | 100% |  |  |  |  |  |  | EC281232 | EC281232 | 87A | 12 |  | IPR | E | C | EC28 | 1232 | cq | LND | 1211C21 | 200 |  |  |  |  |  |  |  |  |
|  | M | **M Mechanical - Rotating Equipment** |  |  | 2008-03-07 | 2009-10-30 |  |  |  |  |  |  |  |  |  |  |  |  |  |  |  |  |  |  |  |  |  |  |  |  |  |  |  |  |  |  |
| E3M0220 |  | M02 Recycle Gas Compr. - Techn. Eval./PO Spec. |  | 55d | 2008-03-07 A | 2008-05-28 A | F6210, P3M02C FF | 100% |  |  |  |  |  |  | E3M0220 | E3M0220 | 867 | 12 | E | LND | E | M | EM14 | 1232 | I | LND | DC | 200 | 200 | M02 | 2DC8490 | 400 | 3A | C2 |  |  |
| E3M0230 |  | M02 Recycle Gas Compr. -Techn. Eval./Bid Tab F | milestone | 0d | 2008-04-29 A | 2008-04-29 A | F6290, P3M02C FF-5d | 100% |  |  |  |  |  |  | E3M0230 | E3M0230 | 867 | 12 | E | LND | E | M | EM14 | 1232 | I | LND |  | 200 | 200 | M02 | 2DC8490 | 055 |  | C2 |  |  |
| E3M0240 |  | M02 Recycle Gas Compr. - 1st Review Vendor Dwgs |  | 19d | 2008-07-17 A | 2008-08-12 A | P3M02D FS+35d | 100% |  |  |  |  |  |  | E3M0240 | E3M0240 | 867 | 12 | E | LND | E | M | EM15 | 1232 | I | LND | DC | 200 | 200 | M02 | 2DC8490 | 400 | 3A | C2 | DFA |  |
| E3M0250 |  | M02 Recycle Gas Compr. - Vendor dwgs approved | milestone | 0d | 2008-08-13 A | 2008-08-13 A | E3M0240 FF | 100% |  | 959,216 | 959,216 |  |  |  | E3M0250 | E3M0250 | 867 | 12 | E | LND | E | M | EM15 | 1232 | I | LND | DC | 200 | 200 | M02 | 2DC8490 | 400 |  | C2 |  |  |
| EM051232 |  | CA12 R.G.Compressor - Final Loads for Civil | milestone | 0d | 2008-09-06 A | 2008-09-06 A | E3M0240 | 100% |  |  |  |  |  |  | EM051232 | EM051232 | 867 | 12 |  | LND | E | M | EM05 | 1232 | I | LND |  | 200 |  |  |  |  |  |  |  |  |
| E3M0260 |  | M02 Recycle Gas Compr. - 2nd Review Vendor Dwgs |  | 15d | 2008-09-08 A | 2008-09-26 A | E3M0250, E3M0240 FS+15d | 100% |  |  |  |  |  |  | E3M0260 | E3M0260 | 867 | 12 | E | LND | E | M | EM15 | 1232 | I | LND | DC | 200 | 200 | M02 | 2DC8490 | 400 |  | C2 |  |  |
| E3M0265 |  | M02 Recycle Gas Compr. - 2nd Review Rejustment Vendor Dwgs |  | 15d | 2009-10-12 A | 2009-10-30 A | E3M0260 | 100% | TAM [640 h] |  |  |  |  |  | E3M0265 | E3M0265 | 867 | 12 | E | LND | E | M | EM15 | 1232 | I | LND | DC | 200 | 200 | M02 | 2DC8490 | 400 |  | C2 |  | 640,00 |
|  | R | **R Piping** |  |  | 2008-04-01 | 2011-02-04 |  |  |  |  |  |  |  |  |  |  |  |  |  |  |  |  |  |  |  |  |  |  |  |  |  |  |  |  |  |  |
| ER151232 |  | CA12 R.G.Compressor - Conceptual Piping |  | 169d | 2008-04-01 A | 2008-11-28 A | F2760 | 100% |  |  |  |  |  |  | ER151232 | ER151232 | 876 | 12 |  | LND | E | R | ER15 | 1232 | PL | LND |  | 200 |  |  |  |  |  |  |  |  |
| ER301232 |  | CA12 R.G.Compressor - CAD Model Piping / Eqpt |  | 517d | 2008-07-01 A | 2010-07-23 A | ER391232 FF+10d, HER30 FF, ER151232 SS | 100% |  |  |  |  |  |  | ER301232 | ER301232 | 876 | 12 |  | LNI | E | R | ER30 | 1232 | PL | LND |  | 200 |  |  |  |  |  |  |  |  |
| ER161232 |  | CA12 R.G.Compressor - prel Loads for Civil |  | 20d | 2009-01-05 A | 2009-01-30 A | ER151232 FF | 100% |  |  |  |  |  |  | ER161232 | ER161232 | 876 | 12 |  | LND | E | R | ER16 | 1232 | PL | LND |  | 200 |  |  |  |  |  |  |  |  |
| ER361232 |  | CA12 R.G.Compressor - CAD Model Review 60% |  | 12d | 2009-11-02 A | 2009-11-17 A | F4030 SS | 100% |  |  |  |  |  |  | ER361232 | ER361232 | 876 | 12 |  | LND | E | R | ER36 | 1232 | 2 | LND |  | 200 |  |  |  |  |  |  |  |  |
| ER421232 |  | CA12 R.G.Compressor - Stress Calculation |  | 98d | 2009-11-16 A | 2010-04-09 A | HER42 FF, ER361232 | 100% |  |  |  |  |  |  | ER421232 | ER421232 | 872 | 12 |  | LND | E | R | ER42 | 1232 | PL | LND |  | 200 |  |  |  |  |  |  |  |  |
| ER191232 |  | CA12 R.G.Compressor - Final Loads for Civil | milestone | 0d | 2010-01-18 A | 2010-01-18 A | EC261232 SF-10d, F4030 SF+20d, ER161232 FF | 100% |  |  |  |  |  |  | ER191232 | ER191232 | 876 | 12 |  | LNI | E | R | ER19 | 1232 | PL | LND |  | 200 |  |  |  |  |  |  |  |  |
| ER391232 |  | CA12 R.G.Compressor - CAD Model Review 90% |  | 10d | 2010-06-28 A | 2010-07-09 A | F4460 FF | 100% |  |  |  |  |  |  | ER391232 | ER391232 | 876 | 12 |  | LND | E | R | ER39 | 1232 | 3 | LND |  | 200 |  |  |  |  |  |  |  |  |
| ER451232 |  | CA12 R.G.Compressor - Piping Isometrics |  | 119d | 2010-07-05 A | 2010-12-17 A | ER301232 FF+15d, ER421232, ER391232 FF+25d | 100% |  |  |  |  |  |  | ER451232 | ER451232 | 876 | 12 |  | LEI | E | R | ER45 | 1232 | 5 | LND |  | 200 |  |  |  |  |  |  |  |  |
| ER491232 |  | CA12 R.G.Compressor - Design Check/ Rel.Isos&BOM |  | 110d | 2010-09-01 A | 2011-02-04 A | ER451232 SS+20d | 100% |  |  |  |  |  |  | ER491232 | ER491232 | 876 | 12 |  | LEI | E | R | ER49 | 1232 | 5 | LND |  | 200 |  |  |  |  |  |  |  |  |

Notes:
- E3M0250: Expenses: 900A 959216

| ID | WBS | Activity | Type | Duration | Start | Finish | Predecessors | Complete | Resources | Cost | Actual cost | UDF_CONTRACT START DATE | UDF_CONTRACT FINISH DATE | UDF_CONTRACT ITEM | UDF_SAVE ACTID | UDF_SAVE ACT ID | Department | Constr. Area | PMT-Phase | PMT-Respons. | WBS Phase | WBS Discipline | WBS Type of Work | WBS Objects | IMS | UPT | Pro Unit/DocCode | PMT-Area | PMT-Schedule Org | Type of Work | Inquiry/Order No | PMT-Discipline | PMT-Stage | Zeigen/n. Zeigen | PMT-Doc. Type | TB26 Ressource Budget |
| --- | --- | --- | --- | --- | --- | --- | --- | --- | --- | --- | --- | --- | --- | --- | --- | --- | --- | --- | --- | --- | --- | --- | --- | --- | --- | --- | --- | --- | --- | --- | --- | --- | --- | --- | --- | --- |
|  | E | **E Electrical** |  |  | 2009-05-07 | 2010-07-30 |  |  |  |  |  |  |  |  |  |  |  |  |  |  |  |  |  |  |  |  |  |  |  |  |  |  |  |  |  |  |
| EE901232 |  | CA12 R.G.Compressor - Earthing Details |  | 30d | 2009-05-07 A | 2009-06-19 A | EE901201 SS | 100% |  |  |  | 2011-05-10 | 2011-12-10 | E-16-07-03 | EE901232 | EE901232 | 874 | 12 | E | LND | E | E | EE90 | 1232 | E | LND |  |  |  |  |  |  |  |  |  |  |
| EE46123210 |  | CA12 R.G.Compressor - El. CableTray Layout Pl. / LOP's 1st Issue |  | 162d | 2009-12-07 A | 2010-07-30 A | F4030 FF+75d, EE460000 | 100% |  |  |  | 2011-05-10 | 2011-12-10 | E-16-07-03 | EE46123210 | EE46123210 | 874 | 12 | E | LEI | E | E | EE46 | 1232 | E | LND |  |  |  |  |  |  |  |  |  |  |
| EE561232 |  | CA12 R.G.Compressor - Cable Pulling Details |  | 159d | 2009-12-10 A | 2010-07-30 A | EE500130, EE46123210 FF | 100% |  |  |  | 2011-05-10 | 2011-12-10 | E-16-07-03 | EE561232 | EE561232 | 874 | 12 | E | LEI | E | E | EE56 | 1232 | E | LND |  |  |  |  |  |  |  |  |  |  |
|  | J | **J Instrumentation** |  |  | 2010-02-03 | 2010-11-26 |  |  |  |  |  |  |  |  |  |  |  |  |  |  |  |  |  |  |  |  |  |  |  |  |  |  |  |  |  |  |
| EJ361232 |  | CA12 R.G.Compressor - Hook-Up drwgs 1st Issue |  | 90d | 2010-02-03 A | 2010-06-14 A | F4030 FS+50d, A1EJ0080 | 100% |  |  |  |  |  |  | EJ361232 | EJ361232 | 86E | 12 | C | LEI | E | J | EJ36 | 1232 | I | LND | 999 | 200 | 200 |  |  |  |  |  |  |  |
| EJ46123210 |  | CA12 R.G.Compressor - Instr CableTray Layout Pl. 1st Issue |  | 106d | 2010-03-01 A | 2010-07-30 A | EE46123210 FF, F4460, F4030 FF | 100% |  |  |  |  |  |  | EJ46123210 | EJ46123210 | 86E | 12 | E | LEI | E | J | EJ41 | 1232 | I | LND | 999 |  |  |  |  |  |  |  |  |  |
| EJ321232 |  | CA12 R.G.Compressor - JB Location drwgs |  | 25d | 2010-07-12 A | 2010-08-13 A | F4460 FF+25d, F4030 | 100% |  |  |  |  |  |  | EJ321232 | EJ321232 | 86E | 12 | C | LEI | E | J | EJ37 | 1232 | I | LND | 999 | 200 | 200 |  |  |  |  |  |  |  |
| EJ801232 |  | CA12 R.G.Compressor - Loop Diagrams |  | 70d | 2010-08-20 A | 2010-11-26 A | A1EJ0040 SF, EJ800010 | 100% |  |  |  |  |  |  | EJ801232 | EJ801232 | 86E | 12 | E | LEI | E | J | EJ80 | 1232 | I | LND | 999 |  |  |  |  |  |  |  |  |  |
|  | 1233 | **1233 Bleed Booster Compressor - CA12** |  |  | 2008-04-01 | 2011-10-18 |  |  |  |  |  |  |  |  |  |  |  |  |  |  |  |  |  |  |  |  |  |  |  |  |  |  |  |  |  |  |
|  | C | **C Civil** |  |  | 2009-01-02 | 2010-09-30 |  |  |  |  |  |  |  |  |  |  |  |  |  |  |  |  |  |  |  |  |  |  |  |  |  |  |  |  |  |  |
| EC241233 |  | CA12 B.B.Compressor - Layout Drwg / Loads IFD |  | 20d | 2009-01-02 A | 2009-01-29 A | ER161233, EM051233 | 100% |  |  |  |  |  |  | EC241233 | EC241233 | 87A | 12 |  | LND | E | C | EC24 | 1233 | de | LND | 1212C01 | 200 |  |  |  |  |  |  |  |  |
| EC151233 |  | CA12 B.B.Compressor - Piling drwgs AFC |  | 50d | 2010-02-01 A | 2010-04-13 A | EC151201 FF, EC261233 SS | 100% |  |  |  |  |  |  | EC151233 | EC151233 | 87A | 12 |  | IPR | E | C | EC15 | 1233 | PI | LND | 1212C16 | 200 |  |  |  |  |  |  |  |  |
| EC261233 |  | CA12 B.B.Compressor - Civil Static Calc EqptFdtn |  | 170d | 2010-02-01 A | 2010-09-30 A | EC261232 SS, P3C0BD FS+10d, EC241233 | 100% |  |  |  |  |  |  | EC261233 | EC261233 | 87A | 12 |  | IPR | E | C | EC26 | 1233 | de | LND | 1212C14 | 200 |  |  |  |  |  |  |  |  |
| EC281233 |  | CA12 B.B.Compressor - Formw/Reinforce drwgs AFC |  | 139d | 2010-03-01 A | 2010-09-15 A | EC261233 SS+20d, EC151233 SS+20d | 100% |  |  |  |  |  |  | EC281233 | EC281233 | 87A | 12 |  | IPR | E | C | EC28 | 1233 | cq | LND | 1212C21 | 200 |  |  |  |  |  |  |  |  |
|  | M | **M Mechanical - Rotating Equipment** |  |  | 2008-06-25 | 2010-12-30 |  |  |  |  |  |  |  |  |  |  |  |  |  |  |  |  |  |  |  |  |  |  |  |  |  |  |  |  |  |  |
| E3M0420 |  | M04 GasBleedCompr. - Techn. Eval./PO Spec. |  | 51d | 2008-06-25 A | 2008-09-03 A | P3M04C FF | 100% |  |  |  |  |  |  | E3M0420 | E3M0420 | 867 | 12 | E | LND | E | M | EM14 | 1233 | I | LND | DC | 200 | 200 | M04 | 2KB4360 | 400 | 3A | C2 |  |  |
| E3M0430 |  | M04 GasBleedCompr. -Techn. Eval./Bid Tab F | milestone | 0d | 2008-08-01 A | 2008-08-01 A | P3M04C FF-7d, F6690 | 100% |  |  |  |  |  |  | E3M0430 | E3M0430 | 867 | 12 | E | LND | E | M | EM14 | 1233 | I | LND |  | 200 | 200 | M04 | 2KB4360 | 055 |  | C2 |  |  |
| E3M0440 |  | M04 GasBleedCompr. - 1st Review Vendor Dwgs |  | 12d | 2008-11-12 A | 2008-11-28 A | P3M04D FS+47d | 100% |  |  |  |  |  |  | E3M0440 | E3M0440 | 867 | 12 | E | LND | E | M | EM15 | 1233 | I | LND | DC | 200 | 200 | M04 | 2KB4360 | 400 | 3A | C2 | DFA |  |
| E3M0450 |  | M04 GasBleedCompr. - Vendor dwgs approved | milestone | 0d | 2008-11-29 A | 2008-11-29 A | E3M0440 FF | 100% |  | 101,200 | 101,200 |  |  |  | E3M0450 | E3M0450 | 867 | 12 | E | LND | E | M | EM15 | 1233 | I | LND | DC | 200 | 200 | M04 | 2KB4360 | 400 |  | C2 |  |  |
| EM051233 |  | CA12 B.B.Compressor - Final Loads for Civil | milestone | 0d | 2008-12-06 A | 2008-12-06 A | E3M0440 SF | 100% |  |  |  |  |  |  | EM051233 | EM051233 | 867 | 12 |  | LND | E | M | EM05 | 1233 | I | LND |  | 200 |  |  |  |  |  |  |  |  |
| E3M0460 |  | M04 GasBleedCompr. - 2nd Review Vendor Dwgs |  | 20d | 2009-02-16 A | 2009-03-13 A | E3M0440 FS+50d, E3M0450 | 100% |  |  |  |  |  |  | E3M0460 | E3M0460 | 867 | 12 | E | LND | E | M | EM15 | 1233 | I | LND | DC | 200 | 200 | M04 | 2KB4360 | 400 |  | C2 |  |  |
| E3M0465 |  | M04 GasBleedCompr. - 2nd Review Rejustment Vendor Dwgs |  | 81d | 2009-12-03 A | 2010-03-31 A | E3M0460, DE1000 | 100% | TAM [800 h] |  |  |  |  |  | E3M0465 | E3M0465 | 867 | 12 | E | LND | E | M | EM15 | 1233 | I | LND | DC | 200 | 200 | M04 | 2KB4360 | 400 |  | C2 |  | 800,00 |
| E3M0470 |  | M04 GasBleedCompr. - Review Final Documentation |  | 193d | 2010-03-29 A | 2010-12-30 A | P3M04L FF-35d | 100% | TAM [1440 h] |  |  |  |  |  | E3M0470 | E3M0470 | 867 | 12 | E | LND | E | M | EM15 | 1233 | I | LND | DC | 200 | 200 | M04 | 2KB4360 | 400 |  | C2 |  | 1440,00 |
| E3M0475 |  | M04 GasBleedCompr. - Review Instr. Data Sheets / PLC / JB |  | 40d | 2010-07-16 A | 2010-09-09 A | E3M0470 SS+75d | 100% |  |  |  |  |  |  | E3M0475 | E3M0475 | 867 | 12 | E | LND | E | M | EM15 | 1233 | I | LND | DC | 200 | 200 | M04 | 2KB4360 | 400 |  | C2 |  |  |

Notes:
- EE561232: P3 Activity Log Info: UG/Above Ground Details
- E3M0450: Expenses: 900A 101200

| ID | WBS | Activity | Type | Duration | Start | Finish | Predecessors | Complete | Remaining | Total float | Resources | UDF_SAVE ACTID | UDF_SAVE ACT ID | Department | Constr. Area | PMT-Area | PMT-Respons. | WBS Phase | WBS Discipline | WBS Type of Work | WBS Objects | IMS | UPT | UDF_CONTRACT START DATE | UDF_CONTRACT FINISH DATE | UDF_CONTRACT ITEM | PMT-Phase | Pro Unit/DocCode | PMT-Schedule Org | TB26 Ressource Budget | Inquiry/Order No | Zeigen/n. Zeigen |
| --- | --- | --- | --- | --- | --- | --- | --- | --- | --- | --- | --- | --- | --- | --- | --- | --- | --- | --- | --- | --- | --- | --- | --- | --- | --- | --- | --- | --- | --- | --- | --- | --- |
|  | R | **R Piping** |  |  | 2008-04-01 | 2011-02-04 |  |  |  |  |  |  |  |  |  |  |  |  |  |  |  |  |  |  |  |  |  |  |  |  |  |  |
| ER151233 |  | CA12 B.B.Compressor - Conceptual Piping |  | 169d | 2008-04-01 A | 2008-11-28 A | F2760 | 100% |  |  |  | ER151233 | ER151233 | 876 | 12 | 200 | LND | E | R | ER15 | 1233 | PL | LND |  |  |  |  |  |  |  |  |  |
| ER301233 |  | CA12 B.B.Compressor - CAD Model Piping / Eqpt |  | 517d | 2008-07-01 A | 2010-07-23 A | ER151233 SS, ER391233 FF+10d | 100% |  |  |  | ER301233 | ER301233 | 876 | 12 | 200 | LNI | E | R | ER30 | 1233 | PL | LND |  |  |  |  |  |  |  |  |  |
| ER161233 |  | CA12 B.B.Compressor - prel Loads for Civil |  | 20d | 2009-01-05 A | 2009-01-30 A | ER151233 FF | 100% |  |  |  | ER161233 | ER161233 | 876 | 12 | 200 | LND | E | R | ER16 | 1233 | PL | LND |  |  |  |  |  |  |  |  |  |
| ER361233 |  | CA12 B.B.Compressor - CAD Model Review 60% |  | 12d | 2009-11-02 A | 2009-11-17 A | F4030 SS | 100% |  |  |  | ER361233 | ER361233 | 876 | 12 | 200 | LND | E | R | ER36 | 1233 | 2 | LND |  |  |  |  |  |  |  |  |  |
| ER421233 |  | CA12 B.B.Compressor - Stress Calculation |  | 98d | 2009-11-16 A | 2010-04-09 A | ER361233 | 100% |  |  |  | ER421233 | ER421233 | 872 | 12 | 200 | LND | E | R | ER42 | 1233 | PL | LND |  |  |  |  |  |  |  |  |  |
| ER191233 |  | CA12 B.B.Compressor - Final Loads for Civil | milestone | 0d | 2010-01-18 A | 2010-01-18 A | F4030 SF+20d, ER161233 FF, EC261233 SF-10d | 100% |  |  |  | ER191233 | ER191233 | 876 | 12 | 200 | LNI | E | R | ER19 | 1233 | PL | LND |  |  |  |  |  |  |  |  |  |
| ER391233 |  | CA12 B.B.Compressor - CAD Model Review 90% |  | 10d | 2010-06-28 A | 2010-07-09 A | F4460 FF | 100% |  |  |  | ER391233 | ER391233 | 876 | 12 | 200 | LND | E | R | ER39 | 1233 | 3 | LND |  |  |  |  |  |  |  |  |  |
| ER451233 |  | CA12 B.B.Compressor - Piping Isometrics |  | 99d | 2010-08-02 A | 2010-12-17 A | ER421233, ER391233 FS+15d, ER301233 FF+20d | 100% |  |  |  | ER451233 | ER451233 | 876 | 12 | 200 | LEI | E | R | ER45 | 1233 | 5 | LND |  |  |  |  |  |  |  |  |  |
| ER491233 |  | CA12 B.B.Compressor - Design Check/ Rel.Isos&BOM |  | 110d | 2010-09-01 A | 2011-02-04 A | ER451233 SS+20d | 100% |  |  |  | ER491233 | ER491233 | 876 | 12 | 200 | LEI | E | R | ER49 | 1233 | 5 | LND |  |  |  |  |  |  |  |  |  |
|  | E | **E Electrical** |  |  | 2009-05-07 | 2011-10-18 |  |  |  |  |  |  |  |  |  |  |  |  |  |  |  |  |  |  |  |  |  |  |  |  |  |  |
| EE901233 |  | CA12 B.B.Compressor - Earthing Details |  | 30d | 2009-05-07 A | 2009-06-19 A | EE901201 SS | 100% |  |  |  | EE901233 | EE901233 | 874 | 12 |  | LND | E | E | EE90 | 1233 | E | LND | 2011-05-10 | 2011-12-10 | E-16-07-03 | E |  |  |  |  |  |
| EE46123310 |  | CA12 B.B.Compressor - El. CableTray Layout Pl. / LOP's 1st Issue |  | 162d | 2009-12-07 A | 2010-07-30 A | EE460000, F4030 FF+75d | 100% |  |  |  | EE46123310 | EE46123310 | 874 | 12 |  | LEI | E | E | EE46 | 1233 | E | LND | 2011-05-10 | 2011-12-10 | E-16-07-03 | E |  |  |  |  |  |
| EE561233 |  | CA12 B.B.Compressor - Cable Pulling Details |  | 159d | 2009-12-10 A | 2010-07-30 A | EE46123310 FF, EE500130 | 100% |  |  |  | EE561233 | EE561233 | 874 | 12 |  | LEI | E | E | EE56 | 1233 | E | LND | 2011-05-10 | 2011-12-10 | E-16-07-03 | E |  |  |  |  |  |
| EE561810 |  | CA18 Chiller Unit Area - Cable Pulling Details |  | 45d | 2011-08-16 A | 2011-10-18 | EE46181010 FF, EE46181020 FF |  | 33d | 418.5d |  | EE561233 | EE561810 | 874 | 18 |  | LEI | E | E | EE56 | 1810 | E | LND | 2011-05-10 | 2011-12-10 | E-16-07-03 | E |  |  |  |  |  |
|  | J | **J Instrumentation** |  |  | 2010-02-03 | 2010-11-26 |  |  |  |  |  |  |  |  |  |  |  |  |  |  |  |  |  |  |  |  |  |  |  |  |  |  |
| EJ361233 |  | CA12 B.B.Compressor - Hook-Up drwgs 1st Issue |  | 90d | 2010-02-03 A | 2010-06-14 A | A1EJ0080, F4030 FS+50d | 100% |  |  |  | EJ361233 | EJ361233 | 86E | 12 | 200 | LEI | E | J | EJ36 | 1233 | I | LND |  |  |  | C | 999 | 200 |  |  |  |
| EJ46123310 |  | CA12 B.B.Compressor - Instr CableTray Layout Pl. 1st Issue |  | 106d | 2010-03-01 A | 2010-07-30 A | F4460, EE46123310 FF, F4030 FF | 100% |  |  |  | EJ46123310 | EJ46123310 | 86E | 12 |  | LEI | E | J | EJ41 | 1233 | I | LND |  |  |  | E | 999 |  |  |  |  |
| EJ321233 |  | CA12 B.B.Compressor - JB Location drwgs |  | 25d | 2010-07-12 A | 2010-08-13 A | F4460 FF+25d, F4030 | 100% |  |  |  | EJ321233 | EJ321233 | 86E | 12 | 200 | LEI | E | J | EJ37 | 1233 | I | LND |  |  |  | C | 999 | 200 |  |  |  |
| EJ801233 |  | CA12 B.B.Compressor - Loop Diagrams |  | 70d | 2010-08-20 A | 2010-11-26 A | EJ800010, A1EJ0040 SF | 100% |  |  |  | EJ801233 | EJ801233 | 86E | 12 |  | LEI | E | J | EJ80 | 1233 | I | LND |  |  |  | E | 999 |  |  |  |  |
|  | 13 | **13 CA13 - Polymerization Line 2** |  |  | 2008-03-03 | 2011-04-15 |  |  |  |  |  |  |  |  |  |  |  |  |  |  |  |  |  |  |  |  |  |  |  |  |  |  |
|  | 1300 | **1300 Generals - CA13** |  |  | 2009-12-01 | 2011-03-31 |  |  |  |  |  |  |  |  |  |  |  |  |  |  |  |  |  |  |  |  |  |  |  |  |  |  |
|  | C | **C Civil** |  |  | 2009-12-01 | 2011-03-31 |  |  |  |  |  |  |  |  |  |  |  |  |  |  |  |  |  |  |  |  |  |  |  |  |  |  |
| EC441300 |  | CA13 General - Civil Layout drwgs / Loads IFD | level of effort | 45d | 2009-12-01 A | 2010-02-05 A | EC221304 FF, EC441321 SS, EC221301 FF, EC441322 SS, EC221301 SS | 100% |  |  |  | EC441300 | EC441300 | 87A | 13 | 200 | LND | E | C | EC44 | 1300 | de | LND |  |  |  | E | 1300C01 |  |  |  |  |
| EC071305 |  | CA13 General - Issue of working drwgs (AFC) by RDI |  | 308d | 2010-01-11 A | 2011-03-25 A | EC601300 FF, EC261301 SS, EC45130110 FF | 100% |  |  | TKB-B [8080 h] | EC071305 | EC071305 | 87A | 13 | 200 | IPR | E | C | EC07 | 1300 | cq | LND |  |  |  | E | 1010C13 |  | 8080,00 | 999 | FL |
| EC071300 |  | CA13 General - Check & Release of working drwgs (AFC) |  | 297d | 2010-02-01 A | 2011-03-31 A | EC601300 FF+4d, EC45130105 SS+35d | 100% |  |  | TKB-B [1424 h] | EC071300 | EC071300 | 87A | 13 | 200 | LND | E | C | EC07 | 1300 | cq | LND |  |  |  | E |  |  | 1424,00 | 999 | FL |
| EC44130005 |  | CA13 General - General Drwgs & Documents |  | 117d | 2010-02-22 A | 2010-08-09 A | EC28130112 FF, EC28130110 FF, EC45130105 FF | 100% |  |  |  | EC44130005 | EC44130005 | 87A | 13 | 200 | IPR | E | C | EC00 | 1300 | de | LND |  |  |  | E | 1300C11 |  |  |  |  |
| EC601300 |  | CA13 General - Paving drwgs AFC -heated- |  | 191d | 2010-06-29 A | 2011-03-25 A | EC301300 SS+30d, EC44130005 FF | 100% |  |  |  | EC601300 | EC601300 | 87A | 13 | 200 | IPR | E | C | EC60 | 1300 | de | LND |  |  |  | E | 9613C96 | 200 |  |  |  |

Notes:
- EE561233: P3 Activity Log Info: UG/Above Ground Details
- EE561810: P3 Activity Log Info: UG/Above Ground Details
- EC441300: P3 Activity Log Info: incl. PMT approval
- EC44130005: P3 Activity Log Info: incl. PMT approval

| ID | WBS | Activity | Type | Duration | Start | Finish | Predecessors | Complete | Calendar | Resources | UDF_SAVE ACTID | UDF_SAVE ACT ID | Department | Constr. Area | PMT-Area | PMT-Schedule Org | PMT-Phase | PMT-Respons. | WBS Phase | WBS Discipline | WBS Type of Work | WBS Objects | IMS | UPT | TB26 Ressource Budget | UDF_Actictity Name (Russia) | Zeigen/n. Zeigen | Pro Unit/DocCode | Type of Work | Inquiry/Order No | PMT-Discipline |
| --- | --- | --- | --- | --- | --- | --- | --- | --- | --- | --- | --- | --- | --- | --- | --- | --- | --- | --- | --- | --- | --- | --- | --- | --- | --- | --- | --- | --- | --- | --- | --- |
|  | R | **R Piping** |  |  | 2010-10-04 | 2010-11-05 |  |  |  |  |  |  |  |  |  |  |  |  |  |  |  |  |  |  |  |  |  |  |  |  |  |
| ER441300 |  | CA13 General - Piping Isometrics (UG) |  | 25d | 2010-10-04 A | 2010-11-05 A | HER44 FF, EC301300 SS+10d, ER440000 FF | 100% |  |  | ER441300 | ER441300 | 876 | 13 | 200 | 200 | E | LND | E | R | ER44 | 1300 | 4 | LND |  |  |  |  |  |  |  |
|  | E | **E Electrical** |  |  | 2010-01-26 | 2010-08-27 |  |  |  |  |  |  |  |  |  |  |  |  |  |  |  |  |  |  |  |  |  |  |  |  |  |
| EE761300 |  | CA13 General - Layout Plan Light.& Sockets 1st Issue |  | 150d | 2010-01-26 A | 2010-08-27 A | EE000140 FF+10d, EE000180 FS+10d | 100% |  | TAE [3904 h] | EE761300 | EE761300 | 874 | 13 |  |  | E | LEI | E | E | EE76 | 1300 | E | LND | 3904,00 |  |  |  |  |  |  |
| HEE76 |  | Lighting & Sockets Layout Dwgs | level of effort | 104d | 2010-01-26 A | 2010-06-24 A | EE761200 SS, EE761700 SS | 100% |  |  | HEE76 | HEE76 | 874 |  |  |  | E | LND | E | E | EE00 | 1300 | E | LND |  | Освещение и розетки, компоновочные чертежи | L2 |  |  |  |  |
|  | 1301 | **1301 Reactor Structure - CA13** |  |  | 2008-03-03 | 2011-04-15 |  |  |  |  |  |  |  |  |  |  |  |  |  |  |  |  |  |  |  |  |  |  |  |  |  |
|  | C | **C Civil** |  |  | 2009-12-01 | 2010-09-02 |  |  |  |  |  |  |  |  |  |  |  |  |  |  |  |  |  |  |  |  |  |  |  |  |  |
| EC221301 |  | CA13 ReactorStruc - Layout Drwg / Loads IFD |  | 20d | 2009-12-01 A | 2009-12-30 A | EN251301 FF, EM051301, EB051301 | 100% |  |  | EC221301 | EC221301 | 87A | 13 | 200 | 200 | E | LND | E | C | EC22 | 1301 | de | LND |  |  |  | 1301C01 |  |  |  |
| EC261301 |  | CA13 ReactorStruc - Civil Static Calc Base+Stru AFC |  | 165d | 2010-01-11 A | 2010-09-02 A | EC221301, P3C0BD FS+15d | 100% |  |  | EC261301 | EC261301 | 87A | 13 | 200 | 200 | E | IPR | E | C | EC26 | 1301 | de | LND |  |  |  | 1301C14 |  |  |  |
| EC45130105 |  | CA13 ReactorStruc - Civil Layout drwgs AFC |  | 116d | 2010-01-11 A | 2010-06-25 A | P3C0BD FS+10d, EC221301, EC261301 SS, AD2230 | 100% |  |  | EC45130105 | EC45130105 | 87A | 13 | 200 |  | E | IPR | E | C | EC45 | 1301 | ar | LND |  |  |  | 1301C13 |  |  |  |
| EC151301 |  | CA13 ReactorStruc - Piling drwgs AFC |  | 35d | 2010-02-01 A | 2010-03-19 A | EC261301 SS+15d | 100% |  |  | EC151301 | EC151301 | 87A | 13 | 200 |  |  | IPR | E | C | EC15 | 1301 | PI | LND |  |  |  | 1301C16 |  |  |  |
| EC28130105 |  | CA13 ReactorStruc - Formw/Reinf drwgs Baseplate AFC |  | 73d | 2010-02-15 A | 2010-06-01 A | EC151301 SS+10d, EC261301 SS+20d | 100% |  |  | EC28130105 | EC28130105 | 87A | 13 | 200 | 200 | E | IPR | E | C | EC28 | 1301 | cq | LND |  |  |  | 1301C21 |  |  |  |
| EC28130110 |  | CA13 ReactorStruc - Formw/Reinf drwgs Struc +6m AFC - Columns |  | 96d | 2010-03-15 A | 2010-07-30 A | EC28130105 SS+20d | 100% |  |  | EC28130110 | EC28130110 | 87A | 13 | 200 | 200 | E | IPR | E | C | EC28 | 1301 | ar | LND |  |  |  | 1301C32 |  |  |  |
| EC28130112 |  | CA13 ReactorStruc - Formw/Reinf drwgs Struc +6m AFC - Beams |  | 116d | 2010-03-15 A | 2010-08-27 A | EC28130105 SS+20d | 100% |  |  | EC28130112 | EC28130112 | 87A | 13 | 200 | 200 | E | IPR | E | C | EC28 | 1301 | ar | LND |  |  |  | 1301C32 |  |  |  |
| EC45130110 |  | CA13 ReactorStruc - Civil Layout drwgs IFC | milestone | 0d | 2010-06-11 A | 2010-06-11 A | EC45130105 FF-14d | 100% |  |  | EC45130110 | EC45130110 | 87A | 13 | 200 |  | E | IPR | E | C | EC45 | 1301 | ar | LND |  |  |  |  |  |  |  |
|  | N | **N Structural Steel** |  |  | 2008-03-03 | 2011-04-15 |  |  |  |  |  |  |  |  |  |  |  |  |  |  |  |  |  |  |  |  |  |  |  |  |  |
| EN151301 |  | CA13 ReactorStr SK1301-CAD Model/Concepts StrSte |  | 126d | 2008-03-03 A | 2008-08-29 A | AD2230 FF | 100% |  |  | EN151301 | EN151301 | 87B | 13 | 200 | 200 | E | LND | E | N | EN15 | 1301 | de | LND |  |  | 0 |  | N02G | N02G | 055 |
| EN151303 |  | CA13 SB1303 - CAD Model/Concepts StrSteel |  | 126d | 2008-03-03 A | 2008-08-29 A | AD2230 FF | 100% |  |  | EN151303 | EN151303 | 87B | 13 | 200 | 200 | E | LND | E | N | EN15 | 1303 | de | LND |  |  | 0 |  | N02I | N02I | 055 |
| EN21130105 |  | CA13 ReactorStr SK1301 - GA-Drwgs + Fdtn Loads |  | 126d | 2009-02-09 A | 2009-08-10 A | EE46130105, AD2230 FS+30d, EN151301, E3A0740 SS, E3M1120 FF, E3A0540 SS, ER161301, E3A04A40 SF-10d, E3ALL140 SS, EJ46130105, E3A0440 SS | 100% |  |  | EN21130105 | EN21130105 | 87B | 13 | 200 |  | E | LND | E | N | EN21 | 1301 | de | LND |  |  |  |  | N02G | N02G |  |
| EN24130105 |  | CA13 ReactorStr SK1301- StaticCalc f.Fdtn Loads |  | 25d | 2009-08-24 A | 2009-09-25 A | EN21130105 | 100% |  | TKB-S [320 h] | EN24130105 | EN24130105 | 87B | 13 | 200 |  | E | LND | E | N | EN24 | 1301 | de | LND | 320,00 |  |  |  | N02G | N02G |  |
| EN251301 |  | CA13 ReactorStr SK1301 - Loads for Civil | milestone | 0d | 2009-11-02 A | 2009-11-02 A | EN24130105 FF+15d | 100% |  |  | EN251301 | EN251301 | 87B | 13 | 200 | 200 | E | LND | E | N | EN25 | 1301 | de | LND |  |  | 0 |  | N02G | N02G | 055 |
| EN21130110 |  | CA13 ReactorStr SK1301 - GA-Drwgs + Final Loads |  | 127d | 2009-12-28 A | 2010-06-30 A | EN251301, EE46130108 FF, EJ46130108 FF, EB051301, EN21120110 SS+3d, F4030 FS+25d, EN21130105 FS+10d, EM051301 | 100% |  | TKB-S [960 h] | EN21130110 | EN21130110 | 87B | 13 | 200 |  | E | LEI | E | N | EN21 | 1301 | de | LND | 960,00 |  |  |  | N02G | N02G |  |
| EN24130110 |  | CA13 ReactorStr SK1301 - Final Static Calc |  | 164d | 2009-12-28 A | 2010-08-20 A | EN21130110 SS, ER191301 FF | 100% |  | TKB-S [960 h] | EN24130110 | EN24130110 | 87B | 13 | 200 |  | E | LEI | E | N | EN24 | 1301 | de | LND | 960,00 |  |  |  | N02G | N02G |  |
| EN21130310 |  | CA13 SB1303 - GA-Drwgs + Final Loads |  | 59d | 2010-01-11 A | 2010-04-01 A | EN21120110 SS+5d | 100% |  | TKB-S [192 h] | EN21130310 | EN21130310 | 87B | 13 | 200 |  | E | LEI | E | N | EN21 | 1303 | de | LND | 192,00 |  |  |  | N02I | N02I |  |
| EN24130310 |  | CA13 SB1303 - Final Static Calc |  | 92d | 2010-01-11 A | 2010-05-21 A | EN21130310 SS | 100% |  | TKB-S [320 h] | EN24130310 | EN24130310 | 87B | 13 | 200 |  | E | LEI | E | N | EN24 | 1303 | de | LND | 320,00 |  |  |  | N02I | N02I |  |
| EN261301 |  | CA13 ReactorStr SK1301-Layout drwgs input for KM |  | 95d | 2010-04-20 A | 2010-09-01 A | EN24130110 FF, F4030 FF+20d | 100% |  | TKB-S [2240 h] | EN261301 | EN261301 | 87B | 13 | 200 |  | E | LEI | E | N | EN26 | 1301 | st | LND | 2240,00 |  |  |  | N02G | N02G |  |
| EN261303 |  | CA13 SB1303 - Layout dwgs input for KM dwgs |  | 186d | 2010-05-10 A | 2011-01-31 A | F4030 FF+20d, EN24130310 FF+23d | 100% |  | TKB-S [320 h] | EN261303 | EN261303 | 87B | 13 | 200 |  | E | LEI | E | N | EN26 | 1303 | st | LND | 320,00 |  |  |  | N02I | N02I |  |
| EN671301 |  | CA13 ReactorStr SK1301 - Grating Cut-Out drwgs |  | 112d | 2010-05-27 A | 2010-10-29 A | F4460 FF+10d, ER421301 FF, EN261301 FF+10d | 100% |  | TKB-S [1160 h] | EN671301 | EN671301 | 87B | 13 | 200 | 200 | C | LEI | E | N | EN67 | 1301 | de | LND | 1160,00 |  |  |  | N02G | N02G |  |
| EN801301 |  | CA13 ReactorStr SK1301 - Cladding drwgs |  | 55d | 2010-06-28 A | 2010-08-30 A | ER391301, HEN80 FF | 100% | TB26 - S - Constr-Sumpf | TKB-S [160 h] | EN801301 | EN801301 | 87B | 13 | 200 | 200 | C | Chel | E | N | EN80 | 1301 | de | LND | 160,00 |  |  |  | N02G | N02G |  |
| EN27130105 |  | CA13 ReactorStr SK1301 - KM drwgs |  | 41d | 2010-09-03 A | 2010-10-29 A | EN261301, EN24130105 | 100% |  | KM Drwgs preparation by Cheljabinsk [704 t] | EN27130105 | EN27130105 | 87B | 13 | 200 |  | E | Chel | E | N | EN27 | 1301 | de | LND | 0,00 |  |  |  | N02G | N02G |  |
| EN641301 |  | CA13 ReactorStr SK1301 - Check Grating Cut-Out drwgs |  | 14d | 2010-11-08 A | 2010-11-26 A | EN671301 | 100% |  |  | EN641301 | EN641301 | 87B | 13 | 200 | 200 | C | LEI | E | N | EN67 | 1301 | de | LND |  |  |  |  | N02G | N02G |  |
| EN27130110 |  | CA13 ReactorStr SK1301 - Check KM drwgs |  | 10d | 2010-11-08 A | 2010-11-22 A | EN27130105 FS+5d | 100% |  |  | EN27130110 | EN27130110 | 87B | 13 | 200 |  |  | LEI | E | N | EN27 | 1301 | de | LND |  |  |  |  | N02G | N02G |  |
| EN281301 |  | CA13 ReactorStr SK1301 - Shop dwgs(KMD) by Vendor |  | 30d | 2010-11-23 A | 2011-01-05 A | EN27130110 | 100% |  |  | EN281301 | EN281301 | 87B | 13 | 200 |  | E | Chel | E | N | EN28 | 1301 | de | LND |  |  |  |  | N02G | N02G |  |
| EN681301 |  | CA13 ReactorStr SK1301-Grating Fabrication drwgs |  | 20d | 2010-11-23 A | 2010-12-20 A | EN281301 SS, EN641301, EN671301 | 100% |  |  | EN681301 | EN681301 | 87B | 13 | 200 | 200 | C | Chel | E | N | EN68 | 1301 | de | LND |  |  |  |  | N02G | N02G |  |
| EN27130305 |  | CA13 SB1303 - KM drwgs |  | 28d | 2010-12-21 A | 2011-01-31 A | EN261303 | 100% |  | KM Drwgs preparation by Cheljabinsk [54 t] | EN27130305 | EN27130305 | 87B | 13 | 200 |  | E | Chel | E | N | EN27 | 1303 | de | LND | 0,00 |  |  |  | N02I | N02I |  |
| EN27130310 |  | CA13 SB1303 - Check KM drwgs |  | 20d | 2011-02-07 A | 2011-03-04 A | EN27130305 FS+5d | 100% |  |  | EN27130310 | EN27130310 | 87B | 13 | 200 |  |  | LEI | E | N | EN27 | 1303 | de | LND |  |  |  |  | N02I | N02I |  |
| EN281303 |  | CA13 SB1303 - Shop dwgs(KMD) by Vendor |  | 30d | 2011-03-07 A | 2011-04-15 A | EN27130310 | 100% |  |  | EN281303 | EN281303 | 87B | 13 | 200 |  | E | Chel | E | N | EN28 | 1303 | de | LND |  |  |  |  | N02I | N02I |  |

Notes:
- EC221301: P3 Activity Log Info: TKB-B Keyplan to Subcontractor
- EC45130105: P3 Activity Log Info: incl. PMT approval
- EC45130110: P3 Activity Log Info: incl. PMT approval

| ID | WBS | Activity | Type | Duration | Start | Finish | Predecessors | Complete | UDF_SAVE ACTID | UDF_SAVE ACT ID | Department | Constr. Area | PMT-Area | PMT-Respons. | WBS Phase | WBS Discipline | WBS Type of Work | WBS Objects | IMS | UPT | UDF_CONTRACT START DATE | UDF_CONTRACT FINISH DATE | UDF_CONTRACT ITEM | PMT-Phase | Pro Unit/DocCode | PMT-Schedule Org |
| --- | --- | --- | --- | --- | --- | --- | --- | --- | --- | --- | --- | --- | --- | --- | --- | --- | --- | --- | --- | --- | --- | --- | --- | --- | --- | --- |
|  | B | **B Mechanical - Stationary Equipment** |  |  | 2009-01-24 | 2009-01-24 |  |  |  |  |  |  |  |  |  |  |  |  |  |  |  |  |  |  |  |  |
| EB051301 |  | CA13 ReactorStruc - Final Loads for Struc Steel | milestone | 0d | 2009-01-24 A | 2009-01-24 A | E3A0440, E3ALL140, E3U1520 SF, E3A04A40 SF, E3A0740, E3A0540 | 100% | EB051301 | EB051301 | 869 | 13 | 200 | LND | E | B | EB05 | 1301 | 3 | LND |  |  |  |  |  |  |
|  | M | **M Mechanical - Rotating Equipment** |  |  | 2008-11-29 | 2008-11-29 |  |  |  |  |  |  |  |  |  |  |  |  |  |  |  |  |  |  |  |  |
| EM051301 |  | CA13 ReactorStruc - Final Loads for Struc Steel | milestone | 0d | 2008-11-29 A | 2008-11-29 A | E3M0640, E3M1120 FF, E3U1520 SF, E3M0540 SF | 100% | EM051301 | EM051301 | 867 | 13 | 200 | LND | E | M | EM05 | 1301 | I | LND |  |  |  |  |  |  |
|  | R | **R Piping** |  |  | 2008-04-01 | 2011-01-07 |  |  |  |  |  |  |  |  |  |  |  |  |  |  |  |  |  |  |  |  |
| ER151301 |  | CA13 ReactorStruc - Conceptual Piping |  | 169d | 2008-04-01 A | 2008-11-28 A | F2760 | 100% | ER151301 | ER151301 | 876 | 13 | 200 | LND | E | R | ER15 | 1301 | PL | LND |  |  |  |  |  |  |
| ER151303 |  | CA13 SB1303 - Conceptual Piping |  | 169d | 2008-04-01 A | 2008-11-28 A | F2760 | 100% | ER151303 | ER151303 | 876 | 13 | 200 | LND | E | R | ER15 | 1303 | PL | LND |  |  |  |  |  |  |
| ER301301 |  | CA13 ReactorStruc - CAD Model Piping / Eqpt |  | 517d | 2008-07-01 A | 2010-07-23 A | ER151301 SS, ER391301 FF+10d | 100% | ER301301 | ER301301 | 876 | 13 | 200 | LNI | E | R | ER30 | 1301 | PL | LND |  |  |  |  |  |  |
| ER161301 |  | CA13 ReactorStruc - prel Loads for SteelStruc |  | 20d | 2009-01-05 A | 2009-01-30 A | ER151301 FF | 100% | ER161301 | ER161301 | 876 | 13 | 200 | LND | E | R | ER16 | 1301 | PL | LND |  |  |  |  |  |  |
| ER161303 |  | CA13 SB1303 - prel Loads for Steel Str |  | 20d | 2009-01-05 A | 2009-01-30 A | ER151303 FF | 100% | ER161303 | ER161303 | 876 | 13 | 200 | LND | E | R | ER16 | 1303 | PL | LND |  |  |  |  |  |  |
| ER361301 |  | CA13 ReactorStruc - CAD Model Review 60% |  | 12d | 2009-11-02 A | 2009-11-17 A | F4030 SS | 100% | ER361301 | ER361301 | 876 | 13 | 200 | LND | E | R | ER36 | 1301 | 2 | LND |  |  |  |  |  |  |
| ER421301 |  | CA13 ReactorStruc - Stress Calculation |  | 98d | 2009-11-16 A | 2010-04-09 A | ER361301 | 100% | ER421301 | ER421301 | 872 | 13 | 200 | LND | E | R | ER42 | 1301 | PL | LND |  |  |  |  |  |  |
| ER191301 |  | CA13 ReactorStruc - Final Loads for SteelStruc | milestone | 0d | 2010-01-04 A | 2010-01-04 A | F4030 SF+20d, EN21130110 SF-5d, ER161301 FF | 100% | ER191301 | ER191301 | 876 | 13 | 200 | LNI | E | R | ER19 | 1301 | PL | LND |  |  |  |  |  |  |
| ER191303 |  | CA13 SB1303 - Final Loads for Steel Str | milestone | 0d | 2010-01-04 A | 2010-01-04 A | EN21130310 SF-10d, ER161303 FF, F4030 FF+5d | 100% | ER191303 | ER191303 | 876 | 13 | 200 | LNI | E | R | ER19 | 1303 | PL | LND |  |  |  |  |  |  |
| ER391301 |  | CA13 ReactorStruc - CAD Model Review 90% |  | 10d | 2010-06-28 A | 2010-07-09 A | F4460 FF | 100% | ER391301 | ER391301 | 876 | 13 | 200 | LND | E | R | ER39 | 1301 | 3 | LND |  |  |  |  |  |  |
| ER451301 |  | CA13 ReactorStruc - Piping Isometrics |  | 117d | 2010-07-12 A | 2010-12-22 A | ER391301 FF+30d, ER421301, ER301301 FF+20d | 100% | ER451301 | ER451301 | 876 | 13 | 200 | LEI | E | R | ER45 | 1301 | 5 | LND |  |  |  |  |  |  |
| ER491301 |  | CA13 ReactorStruc - Design Check / Rel.Isos&BOM |  | 90d | 2010-09-01 A | 2011-01-07 A | ER451301 FF | 100% | ER491301 | ER491301 | 876 | 13 | 200 | LEI | E | R | ER49 | 1301 | 5 | LND |  |  |  |  |  |  |
|  | E | **E Electrical** |  |  | 2008-10-06 | 2010-07-30 |  |  |  |  |  |  |  |  |  |  |  |  |  |  |  |  |  |  |  |  |
| EE46130105 |  | CA13 ReactorStruc - prelimLoads f.Civil/StrSteel |  | 15d | 2008-10-06 A | 2008-10-24 A | F3060 FF | 100% | EE46130105 | EE46130105 | 874 | 13 |  | LND | E | E | EE11 | 1301 | E | LND | 2011-06-10 | 2011-10-30 | E-16-07-04 | E |  |  |
| EE901301 |  | CA13 ReactorStruc - Earthing Details |  | 30d | 2009-05-07 A | 2009-06-19 A | EE901201 SS | 100% | EE901301 | EE901301 | 874 | 13 |  | LND | E | E | EE90 | 1301 | E | LND | 2011-06-10 | 2011-10-30 | E-16-07-04 | E |  |  |
| EE46130110 |  | CA13 ReactorStruc - El. CableTray Layout Pl. / LOP's 1st Issue |  | 162d | 2009-12-07 A | 2010-07-30 A | F4030 FF+75d, EE460000 | 100% | EE46130110 | EE46130110 | 874 | 13 |  | LEI | E | E | EE46 | 1301 | E | LND | 2011-06-10 | 2011-10-30 | E-16-07-04 | E |  |  |
| EE561301 |  | CA13 ReactorStruc - Cable Pulling Details |  | 159d | 2009-12-10 A | 2010-07-30 A | EE46130110 FF, EE500130 | 100% | EE561301 | EE561301 | 874 | 13 |  | LEI | E | E | EE56 | 1301 | E | LND | 2011-06-10 | 2011-10-30 | E-16-07-04 | E |  |  |
| EE46130108 |  | CA13 ReactorStruc - Final Loads f.Civil/StrSteel |  | 51d | 2009-12-14 A | 2010-02-26 A | EE46130105 | 100% | EE46130108 | EE46130108 | 874 | 13 |  | LEI | E | E | EE12 | 1301 | E | LND | 2011-06-10 | 2011-10-30 | E-16-07-04 | E |  |  |
|  | J | **J Instrumentation** |  |  | 2008-10-06 | 2010-11-26 |  |  |  |  |  |  |  |  |  |  |  |  |  |  |  |  |  |  |  |  |
| EJ46130105 |  | CA13 ReactorStruc - prelimLoads f.Civil/StrSteel |  | 15d | 2008-10-06 A | 2008-10-24 A | F3060 FF | 100% | EJ46130105 | EJ46130105 | 86E | 13 |  | LND | E | J | EJ11 | 1301 | I | LND |  |  |  | E | 999 |  |
| EJ361301 |  | CA13 ReactorStruc - Hook-Up drwgs 1st Issue |  | 90d | 2010-02-03 A | 2010-06-14 A | F4030 FS+50d, A1EJ0080 | 100% | EJ361301 | EJ361301 | 86E | 13 | 200 | LEI | E | J | EJ36 | 1301 | I | LND |  |  |  | C | 999 | 200 |
| EJ46130108 |  | CA13 ReactorStruc - Final Loads f.Civil/StrSteel |  | 10d | 2010-02-15 A | 2010-02-26 A | EJ46130105 | 100% | EJ46130108 | EJ46130108 | 86E | 13 |  | LEI | E | J | EJ12 | 1301 | I | LND |  |  |  | E | 999 |  |
| EJ46130110 |  | CA13 ReactorStruc - Instr Cable Tray Layout Pl. 1st Issue |  | 106d | 2010-03-01 A | 2010-07-30 A | F4030 FF, F4460, EE46130110 FF | 100% | EJ46130110 | EJ46130110 | 86E | 13 |  | LEI | E | J | EJ41 | 1301 | I | LND |  |  |  | E | 999 |  |
| EJ321301 |  | CA13 ReactorStruc - JB Location drwgs |  | 25d | 2010-07-12 A | 2010-08-13 A | F4460 FF+25d, F4030 | 100% | EJ321301 | EJ321301 | 86E | 13 | 200 | LEI | E | J | EJ37 | 1301 | I | LND |  |  |  | C | 999 | 200 |
| EJ801301 |  | CA13 ReactorStruc - Loop Diagrams |  | 70d | 2010-08-20 A | 2010-11-26 A | EJ800010, A1EJ0040 SF | 100% | EJ801301 | EJ801301 | 86E | 13 |  | LEI | E | J | EJ80 | 1301 | I | LND |  |  |  | E | 999 |  |

Notes:
- ER161301: P3 Activity Log Info: incl. Stress Calc for Civil Supports
- EE561301: P3 Activity Log Info: UG/Above Ground Details

| ID | WBS | Activity | Type | Duration | Start | Finish | Predecessors | Complete | Resources | UDF_SAVE ACTID | UDF_SAVE ACT ID | Department | Constr. Area | Pro Unit/DocCode | PMT-Area | PMT-Schedule Org | PMT-Phase | PMT-Respons. | WBS Phase | WBS Discipline | WBS Type of Work | WBS Objects | IMS | UPT | Type of Work | Inquiry/Order No | PMT-Discipline | Zeigen/n. Zeigen | TB26 Ressource Budget |
| --- | --- | --- | --- | --- | --- | --- | --- | --- | --- | --- | --- | --- | --- | --- | --- | --- | --- | --- | --- | --- | --- | --- | --- | --- | --- | --- | --- | --- | --- |
|  | 1303 | **1303 Connection Structure to Extruder Bldg. - CA13** |  |  |  |  |  |  |  |  |  |  |  |  |  |  |  |  |  |  |  |  |  |  |  |  |  |  |  |
|  | N | **N Structural Steel** |  |  |  |  |  |  |  |  |  |  |  |  |  |  |  |  |  |  |  |  |  |  |  |  |  |  |  |
|  | R | **R Piping** |  |  |  |  |  |  |  |  |  |  |  |  |  |  |  |  |  |  |  |  |  |  |  |  |  |  |  |
|  | 1304 | **1304 Connection Structure Reactor to Teal Bldg - CA13** |  |  | 2008-03-03 | 2011-01-07 |  |  |  |  |  |  |  |  |  |  |  |  |  |  |  |  |  |  |  |  |  |  |  |
|  | C | **C Civil** |  |  | 2009-12-22 | 2010-09-30 |  |  |  |  |  |  |  |  |  |  |  |  |  |  |  |  |  |  |  |  |  |  |  |
| EC221304 |  | CA13 TealStr SK1304 - Layout Drwg / Loads IFD |  | 20d | 2009-12-22 A | 2010-01-22 A | EN251304 | 100% |  | EC221304 | EC221304 | 87A | 13 | 1304C01 | 200 | 200 | E | LND | E | C | EC22 | 1304 | de | LND |  |  |  |  |  |
| EC261304 |  | CA13 TealStr SK1304 - Civil Static Calculation |  | 158d | 2010-02-08 A | 2010-09-21 A | EC221304, P3C0BD FS+10d, EC261301 SS+20d | 100% |  | EC261304 | EC261304 | 87A | 13 | 1304C14 | 200 | 200 | E | IPR | E | C | EC26 | 1304 | de | LND |  |  |  |  |  |
| EC45130405 |  | CA13 TealStr SK1204 - Civil Layout drwgs AFC |  | 96d | 2010-02-08 A | 2010-06-25 A | AD2230, HEC45C FF, P3C0BD FS+10d, EC221304 FS+10d, EC261304 SS | 100% |  | EC45130405 | EC45130405 | 87A | 13 | 1304C13 | 200 |  | E | IPR | E | C | EC45 | 1304 | ar | LND |  |  |  |  |  |
| EC151304 |  | CA13 TealStr SK1304 - Piling drwgs AFC |  | 25d | 2010-02-15 A | 2010-03-19 A | EC261304 SS+5d | 100% |  | EC151304 | EC151304 | 87A | 13 | 1304C16 | 200 |  |  | IPR | E | C | EC15 | 1304 | PI | LND |  |  |  |  |  |
| EC28130410 |  | CA13 TealStr SK1304 - Formw/Reinf dwgs Found. |  | 92d | 2010-03-15 A | 2010-07-26 A | EC151304 SS+20d, EC45130415 FF, EC261304 SS+20d, EC48132203 SS-5d | 100% |  | EC28130410 | EC28130410 | 87A | 13 | 1304C21 | 200 | 200 | E | IPR | E | C | EC28 | 1304 | cq | LND |  |  |  |  |  |
| EC28130406 |  | CA13 TealStr SK1304 - Precast Formw/Reinf drwgs AFC |  | 135d | 2010-03-22 A | 2010-09-30 A | EC28130410 FF+20d | 100% |  | EC28130406 | EC28130406 | 87A | 13 | 1304C53 | 200 | 200 | E | IPR | E | C | EC28 | 1304 | PRE | LND |  |  |  |  |  |
| EC45130410 |  | CA13 TealStr SK1304 - Civil Layout drwgs IFC | milestone | 0d | 2010-05-28 A | 2010-05-28 A | EC45130405 FF-14d | 100% |  | EC45130410 | EC45130410 | 87A | 13 |  | 200 |  | E | IPR | E | C | EC45 | 1304 | ar | LND |  |  |  |  |  |
| EC45130415 |  | CA13 TealStr SK1304 - Rev Civil Layout drwgs |  | 10d | 2010-06-01 A | 2010-06-14 A | EC45130410 | 100% |  | EC45130415 | EC45130415 | 87A | 13 |  | 200 |  | E | LND | E | C | EC45 | 1304 | ar | LND |  |  |  |  |  |
|  | N | **N Structural Steel** |  |  | 2008-03-03 | 2010-12-06 |  |  |  |  |  |  |  |  |  |  |  |  |  |  |  |  |  |  |  |  |  |  |  |
| EN151304 |  | CA13 TealStr SK1304-CADModel/Concepts StrSteel |  | 126d | 2008-03-03 A | 2008-08-29 A | AD2230 FF | 100% |  | EN151304 | EN151304 | 87B | 13 |  | 200 | 200 | E | LND | E | N | EN15 | 1304 | de | LND | N02H | N02H | 055 | 0 |  |
| EN21130405 |  | CA13 TealStr SK1304 - GA-Drwgs + Fdtn Loads |  | 15d | 2009-03-02 A | 2009-03-20 A | EE46130405, ER161304, EJ46130405, EN151304, AD2230 FS+45d | 100% |  | EN21130405 | EN21130405 | 87B | 13 |  | 200 |  | E | LND | E | N | EN21 | 1304 | de | LND | N02H | N02H |  |  |  |
| EN24130405 |  | CA13 TealStr SK1304 - Static Calc f.Fdtn Loads |  | 20d | 2009-10-19 A | 2009-11-13 A | EN21130405 | 100% | TKB-S [160 h] | EN24130405 | EN24130405 | 87B | 13 |  | 200 |  | E | LND | E | N | EN24 | 1304 | de | LND | N02H | N02H |  |  | 160,00 |
| EN251304 |  | CA13 TealStr SK1304 - Loads for Civil | milestone | 0d | 2009-12-03 A | 2009-12-03 A | HEN25 FF, EN24130405 FF+13d | 100% |  | EN251304 | EN251304 | 87B | 13 |  | 200 | 200 | E | LND | E | N | EN25 | 1304 | de | LND | N02H | N02H | 055 | 0 |  |
| EN21130410 |  | CA13 TealStr SK1304 - GA-Drwgs + Final Loads |  | 100d | 2009-12-28 A | 2010-05-21 A | EN21130110, EN24130405, EN21130405, EJ46130408 FF, EE46130408 FF, HEN21 FF | 100% | TKB-S [240 h] | EN21130410 | EN21130410 | 87B | 13 |  | 200 |  | E | LEI | E | N | EN21 | 1304 | de | LND | N02H | N02H |  |  | 240,00 |
| EN24130410 |  | CA13 TealStr SK1304 - Final Static Calc |  | 159d | 2009-12-28 A | 2010-08-13 A | ER191304 FF, EN21130410 SS | 100% | TKB-S [320 h] | EN24130410 | EN24130410 | 87B | 13 |  | 200 |  | E | LEI | E | N | EN24 | 1304 | de | LND | N02H | N02H |  |  | 320,00 |
| EN671304 |  | CA13 TealStr SK1304 - Grating Cut-Out drwgs |  | 107d | 2010-05-25 A | 2010-10-20 A | F4460 FF+10d, ER421304 FF, EN261304 FF+10d | 100% | TKB-S [176 h] | EN671304 | EN671304 | 87B | 13 |  | 200 | 200 | C | LEI | E | N | EN67 | 1304 | de | LND | N02H | N02H |  |  | 176,00 |
| EN261304 |  | CA13 TealStr SK1304 - Layout dwgs input for KM |  | 59d | 2010-05-27 A | 2010-08-17 A | F4030 FF+20d, EN24130410 FF, HEN26 FF | 100% | TKB-S [480 h] | EN261304 | EN261304 | 87B | 13 |  | 200 |  | E | LEI | E | N | EN26 | 1304 | st | LND | N02H | N02H |  |  | 480,00 |
| EN27130405 |  | CA13 TealStr SK1304 - KM drwgs |  | 43d | 2010-08-18 A | 2010-10-15 A | EN24130405, EN261304 | 100% | KM Drwgs preparation by Cheljabinsk [60 t] | EN27130405 | EN27130405 | 87B | 13 |  | 200 |  | E | Chel | E | N | EN27 | 1304 | de | LND | N02H | N02H |  |  | 0,00 |
| EN27130410 |  | CA13 TealStr SK1304 - Check KM drwgs |  | 6d | 2010-10-18 A | 2010-10-25 A | EN27130405 | 100% |  | EN27130410 | EN27130410 | 87B | 13 |  | 200 |  |  | LEI | E | N | EN27 | 1304 | de | LND | N02H | N02H |  |  |  |
| EN641304 |  | CA13 TealStr SK1304 - Check Grating Cut-Out drwgs |  | 20d | 2010-10-21 A | 2010-11-18 A | EN671304 | 100% |  | EN641304 | EN641304 | 87B | 13 |  | 200 | 200 | C | LEI | E | N | EN67 | 1304 | de | LND | N02H | N02H |  |  |  |
| EN681304 |  | CA13 TealStr SK1304 -Grating Fabrication drwgs |  | 20d | 2010-10-21 A | 2010-11-18 A | EN671304, HEN68 FF | 100% |  | EN681304 | EN681304 | 87B | 13 |  | 200 | 200 | C | SC | E | N | EN68 | 1304 | de | LND | N02H | N02H |  |  |  |
| EN281304 |  | CA13 TealStr SK1304 - Shop dwgs(KMD) by Vendor |  | 25d | 2010-11-01 A | 2010-12-06 A | EN27130410 FS+5d, IMS-E-000180 FF, HEN28 FF | 100% |  | EN281304 | EN281304 | 87B | 13 |  | 200 |  | E | Chel | E | N | EN28 | 1304 | de | LND | N02H | N02H |  |  |  |

Notes:
- EC221304: P3 Activity Log Info: TKB-B Keyplan to Subcontractor
- EC45130405: P3 Activity Log Info: incl. PMT approval
- EC45130410: P3 Activity Log Info: incl. PMT approval
- EC45130415: P3 Activity Log Info: incl. PMT approval

| ID | WBS | Activity | Type | Duration | Start | Finish | Predecessors | Complete | UDF_SAVE ACTID | UDF_SAVE ACT ID | Department | Constr. Area | PMT-Area | PMT-Respons. | WBS Phase | WBS Discipline | WBS Type of Work | WBS Objects | IMS | UPT | UDF_CONTRACT START DATE | UDF_CONTRACT FINISH DATE | UDF_CONTRACT ITEM | PMT-Phase | Pro Unit/DocCode | PMT-Schedule Org |
| --- | --- | --- | --- | --- | --- | --- | --- | --- | --- | --- | --- | --- | --- | --- | --- | --- | --- | --- | --- | --- | --- | --- | --- | --- | --- | --- |
|  | R | **R Piping** |  |  | 2008-04-01 | 2011-01-07 |  |  |  |  |  |  |  |  |  |  |  |  |  |  |  |  |  |  |  |  |
| ER151304 |  | CA13 TealStr SK1302/4 - Conceptual Piping |  | 169d | 2008-04-01 A | 2008-11-28 A | F2760 | 100% | ER151304 | ER151304 | 876 | 13 | 200 | LND | E | R | ER15 | 1304 | PL | LND |  |  |  |  |  |  |
| ER301304 |  | CA13 TealStr SK1302/4 - CAD Model Piping / Eqpt |  | 517d | 2008-07-01 A | 2010-07-23 A | ER151304 SS, ER391304 FF+10d | 100% | ER301304 | ER301304 | 876 | 13 | 200 | LNI | E | R | ER30 | 1304 | PL | LND |  |  |  |  |  |  |
| ER161304 |  | CA13 TealStr SK1302/4-prel Loads for Steel Struc |  | 20d | 2009-01-05 A | 2009-01-30 A | ER151304 FF | 100% | ER161304 | ER161304 | 876 | 13 | 200 | LND | E | R | ER16 | 1304 | PL | LND |  |  |  |  |  |  |
| ER361304 |  | CA13 TealStr SK1302/4 - CAD Model Review 60% |  | 12d | 2009-11-02 A | 2009-11-17 A | F4030 SS | 100% | ER361304 | ER361304 | 876 | 13 | 200 | LND | E | R | ER36 | 1304 | 2 | LND |  |  |  |  |  |  |
| ER421304 |  | CA13 TealStr SK1302/4 - Stress Calculation |  | 98d | 2009-11-16 A | 2010-04-09 A | ER361304 | 100% | ER421304 | ER421304 | 872 | 13 | 200 | LND | E | R | ER42 | 1304 | PL | LND |  |  |  |  |  |  |
| ER191304 |  | CA13 TealStr SK1304-Fin Loads for Steel Struc | milestone | 0d | 2010-01-04 A | 2010-01-04 A | F4030 FF, EN21130410 SF-10d, ER161304 | 100% | ER191304 | ER191304 | 876 | 13 | 200 | LNI | E | R | ER19 | 1304 | PL | LND |  |  |  |  |  |  |
| ER391304 |  | CA13 TealStr SK1302/4 - CAD Model Review 90% |  | 10d | 2010-06-28 A | 2010-07-09 A | F4460 FF | 100% | ER391304 | ER391304 | 876 | 13 | 200 | LND | E | R | ER39 | 1304 | 3 | LND |  |  |  |  |  |  |
| ER451304 |  | CA13 TealStr SK1302/4 - Piping Isometrics |  | 117d | 2010-07-12 A | 2010-12-22 A | ER391304, ER301304 FF+20d, ER421304, ER451204 SS | 100% | ER451304 | ER451304 | 876 | 13 | 200 | LEI | E | R | ER45 | 1304 | 5 | LND |  |  |  |  |  |  |
| ER491304 |  | CA13 TealStr SK1302/4-Design Check/ Rel.Isos&BOM |  | 80d | 2010-09-15 A | 2011-01-07 A | ER451304 FF | 100% | ER491304 | ER491304 | 876 | 13 | 200 | LEI | E | R | ER49 | 1304 | 5 | LND |  |  |  |  |  |  |
|  | E | **E Electrical** |  |  | 2008-10-06 | 2010-07-30 |  |  |  |  |  |  |  |  |  |  |  |  |  |  |  |  |  |  |  |  |
| EE46130405 |  | CA13 TealStr SK1302/4-prelim Loads f.Struc Steel |  | 15d | 2008-10-06 A | 2008-10-24 A | F3060 FF | 100% | EE46130405 | EE46130405 | 874 | 13 |  | LND | E | E | EE11 | 1304 | E | LND | 2011-05-10 | 2011-11-30 | E-16-07-05 | E |  |  |
| EE901304 |  | CA13 TealStr SK1302/4-Earthing Details |  | 30d | 2009-06-22 A | 2009-07-31 A | EE901201 | 100% | EE901304 | EE901304 | 874 | 13 |  | LND | E | E | EE90 | 1304 | E | LND | 2011-05-10 | 2011-11-30 | E-16-07-05 | E |  |  |
| EE46130410 |  | CA13 TealStr SK1302/4-El. CableTray Layout Pl. 1st Issue |  | 162d | 2009-12-07 A | 2010-07-30 A | F4030 FF+75d, EE460000 | 100% | EE46130410 | EE46130410 | 874 | 13 |  | LEI | E | E | EE46 | 1304 | E | LND | 2011-05-10 | 2011-11-30 | E-16-07-05 | E |  |  |
| EE561304 |  | CA13 TealStr SK1302/4 - Cable Pulling Details |  | 159d | 2009-12-10 A | 2010-07-30 A | EE500130, EE46130410 FF | 100% | EE561304 | EE561304 | 874 | 13 |  | LEI | E | E | EE56 | 1304 | E | LND | 2011-05-10 | 2011-11-30 | E-16-07-05 | E |  |  |
| EE46130408 |  | CA13 TealStr SK1302/4 -Final Loads f.Struc Steel |  | 38d | 2010-02-22 A | 2010-04-16 A | EE46130405 | 100% | EE46130408 | EE46130408 | 874 | 13 |  | LEI | E | E | EE12 | 1304 | E | LND | 2011-05-10 | 2011-11-30 | E-16-07-05 | E |  |  |
|  | J | **J Instrumentation** |  |  | 2008-10-06 | 2010-07-30 |  |  |  |  |  |  |  |  |  |  |  |  |  |  |  |  |  |  |  |  |
| EJ46130405 |  | CA13 TealStr SK1302/4-prelim Loads f.Struc Steel |  | 15d | 2008-10-06 A | 2008-10-24 A | F3060 FF | 100% | EJ46130405 | EJ46130405 | 86E | 13 |  | LND | E | J | EJ11 | 1304 | I | LND |  |  |  | E | 999 |  |
| EJ46130410 |  | CA13 TealStr SK1302/4-Instr CableTray Layout Pl. 1st Issue |  | 106d | 2010-03-01 A | 2010-07-30 A | F4460, EE46130410 FF, F4030 FF | 100% | EJ46130410 | EJ46130410 | 86E | 13 |  | LEI | E | J | EJ41 | 1304 | I | LND |  |  |  | E | 999 |  |
| EJ46130408 |  | CA13 TealStr SK1302/4 -Final Loads f.Struc Steel |  | 14d | 2010-03-15 A | 2010-04-01 A | EJ46130405 | 100% | EJ46130408 | EJ46130408 | 86E | 13 |  | LEI | E | J | EJ12 | 1304 | I | LND |  |  |  | E | 999 |  |
|  | 1305 | **1305 Agitator Removable Unit - CA13** |  |  | 2008-03-03 | 2010-12-28 |  |  |  |  |  |  |  |  |  |  |  |  |  |  |  |  |  |  |  |  |
|  | C | **C Civil** |  |  | 2010-01-11 | 2010-09-21 |  |  |  |  |  |  |  |  |  |  |  |  |  |  |  |  |  |  |  |  |
| EC221305 |  | CA13 AgitatorRemUnit - Layout Drwg / Loads IFD |  | 20d | 2010-01-11 A | 2010-02-05 A | EC441300 FF, EC221205 SS+5d, EN251305 FF | 100% | EC221305 | EC221305 | 87A | 13 | 200 | LND | E | C | EC22 | 1305 | de | LND |  |  |  | E | 1305C01 | 200 |
| EC151305 |  | CA13 AgitatorRemUnit - Piling drwgs AFC |  | 30d | 2010-02-08 A | 2010-03-19 A | EC261305 SS | 100% | EC151305 | EC151305 | 87A | 13 | 200 | IPR | E | C | EC15 | 1305 | PI | LND |  |  |  |  | 1305C16 |  |
| EC261305 |  | CA13 AgitatorRemUnit - Civil Static Calculation |  | 158d | 2010-02-08 A | 2010-09-21 A | P3C0BD FS+10d, EC221305, EC261301 SS+20d | 100% | EC261305 | EC261305 | 87A | 13 | 200 | IPR | E | C | EC26 | 1305 | de | LND |  |  |  | E | 1305C14 | 200 |
| EC45130505 |  | CA13 AgitatorRemUnit - Civil Layout drwgs AFC |  | 87d | 2010-02-08 A | 2010-06-14 A | P3C0BD FS+10d, EC261305 SS, HEC45C FF, AD2230, EC221305 | 100% | EC45130505 | EC45130505 | 87A | 13 | 200 | IPR | E | C | EC45 | 1305 | ar | LND |  |  |  | E | 1305C13 |  |
| EC281305 |  | CA13 AgitatorRemUnit - Formw/Reinforce drwgs AFC |  | 136d | 2010-03-08 A | 2010-09-17 A | EC45130515 FF, EC151305 SS+10d, EC261305 SS+20d | 100% | EC281305 | EC281305 | 87A | 13 | 200 | IPR | E | C | EC28 | 1305 | cq | LND |  |  |  | E | 1305C21 | 200 |
| EC45130515 |  | CA13 AgitatorRemUnit - Rev Civil Layout drwgs |  | 10d | 2010-03-30 A | 2010-04-14 A | EC45130510 | 100% | EC45130515 | EC45130515 | 87A | 13 | 200 | LND | E | C | EC45 | 1305 | ar | LND |  |  |  | E |  |  |
| EC45130510 |  | CA13 AgitatorRemUnit - Civil Layout drwgs IFC | milestone | 0d | 2010-05-28 A | 2010-05-28 A | EC45130505 FF-14d | 100% | EC45130510 | EC45130510 | 87A | 13 | 200 | IPR | E | C | EC45 | 1305 | ar | LND |  |  |  | E |  |  |

Notes:
- EC221305: P3 Activity Log Info: TKB-B Keyplan to Subcontractor
- EC45130505: P3 Activity Log Info: incl. PMT approval
- EC45130515: P3 Activity Log Info: incl. PMT approval
- EC45130510: P3 Activity Log Info: incl. PMT approval

| ID | WBS | Activity | Type | Duration | Start | Finish | Predecessors | Complete | Resources | UDF_SAVE ACTID | UDF_SAVE ACT ID | Department | Type of Work | Constr. Area | Inquiry/Order No | PMT-Area | PMT-Schedule Org | PMT-Discipline | PMT-Phase | PMT-Respons. | Zeigen/n. Zeigen | WBS Phase | WBS Discipline | WBS Type of Work | WBS Objects | IMS | UPT | TB26 Ressource Budget | Pro Unit/DocCode |
| --- | --- | --- | --- | --- | --- | --- | --- | --- | --- | --- | --- | --- | --- | --- | --- | --- | --- | --- | --- | --- | --- | --- | --- | --- | --- | --- | --- | --- | --- |
|  | N | **N Structural Steel** |  |  | 2008-03-03 | 2010-12-28 |  |  |  |  |  |  |  |  |  |  |  |  |  |  |  |  |  |  |  |  |  |  |  |
| EN151305 |  | CA13 Agitator SK1305 -CADModel/Concepts StrSteel |  | 126d | 2008-03-03 A | 2008-08-29 A | AD2230 FF | 100% |  | EN151305 | EN151305 | 87B | N02J | 13 | N02J | 200 | 200 | 055 | E | LND | 0 | E | N | EN15 | 1305 | de | LND |  |  |
| EN21130505 |  | CA13 Agitator SK1305 - GA-Drwgs + Fdtn Loads |  | 15d | 2009-02-23 A | 2009-03-13 A | E3ALL140 SS, P3J07C SF, EN151305, E3M1120 FF, AD2230 FS+40d | 100% |  | EN21130505 | EN21130505 | 87B | N02J | 13 | N02J | 200 |  |  | E | LND |  | E | N | EN21 | 1305 | de | LND |  |  |
| EN24130505 |  | CA13 Agitator SK1305 - Static Calc f.Fdtn Loads |  | 25d | 2009-08-24 A | 2009-09-25 A | EN21130505 | 100% | TKB-S [160 h] | EN24130505 | EN24130505 | 87B | N02J | 13 | N02J | 200 |  |  | E | LND |  | E | N | EN24 | 1305 | de | LND | 160,00 |  |
| EN251305 |  | CA13 Agitator SK1305 - Loads for Civil | milestone | 0d | 2009-11-02 A | 2009-11-02 A | HEN25 FF, EN24130505 FF+10d | 100% |  | EN251305 | EN251305 | 87B | N02J | 13 | N02J | 200 | 200 | 055 | E | LND | 0 | E | N | EN25 | 1305 | de | LND |  |  |
| EN21130510 |  | CA13 Agitator SK1305 - GA-Drwgs + Final Loads |  | 15d | 2009-12-17 A | 2010-01-12 A | EN24130505, EN21120510 FF, EM051305, HEN21 FF, EB051305, EN21130505 | 100% | TKB-S [480 h] | EN21130510 | EN21130510 | 87B | N02J | 13 | N02J | 200 |  |  | E | LEI |  | E | N | EN21 | 1305 | de | LND | 480,00 |  |
| EN24130510 |  | CA13 Agitator SK1305 - Final Static Calc |  | 163d | 2009-12-29 A | 2010-08-20 A | EN21130510 SS+10d | 100% | TKB-S [320 h] | EN24130510 | EN24130510 | 87B | N02J | 13 | N02J | 200 |  |  | E | LEI |  | E | N | EN24 | 1305 | de | LND | 320,00 |  |
| EN261305 |  | CA13 Agitator SK1305 - Layout dwgs input for KM |  | 67d | 2010-05-26 A | 2010-08-26 A | HEN26 FF, EN24130510 FF, F4030 FF+20d | 100% | TKB-S [800 h] | EN261305 | EN261305 | 87B | N02J | 13 | N02J | 200 |  |  | E | LEI |  | E | N | EN26 | 1305 | st | LND | 800,00 |  |
| EN671305 |  | CA13 Agitator SK1305 - Grating Cut-Out drwgs |  | 113d | 2010-05-26 A | 2010-10-29 A | F4460 FF+10d, EN261305 FF+10d | 100% | TKB-S [720 h] | EN671305 | EN671305 | 87B | N02J | 13 | N02J | 200 | 200 |  | C | LEI |  | E | N | EN67 | 1305 | de | LND | 720,00 |  |
| EN27130505 |  | CA13 Agitator SK1305 - KM drwgs |  | 56d | 2010-08-27 A | 2010-11-12 A | EN24130505, EN261305 | 100% | KM Drwgs preparation by Cheljabinsk [115 t] | EN27130505 | EN27130505 | 87B | N02J | 13 | N02J | 200 |  |  | E | Chel |  | E | N | EN27 | 1305 | de | LND | 0,00 |  |
| EN641305 |  | CA13 Agitator SK1305 - Check Grating Cut-Out drwgs |  | 25d | 2010-10-20 A | 2010-11-24 A | EN671305 | 100% |  | EN641305 | EN641305 | 87B | N02J | 13 | N02J | 200 | 200 |  | C | LEI |  | E | N | EN67 | 1305 | de | LND |  |  |
| EN681305 |  | CA13 Agitator SK1305 -Grating Fabrication drwgs |  | 25d | 2010-10-20 A | 2010-11-24 A | EN671305, HEN68 FF | 100% |  | EN681305 | EN681305 | 87B | N02J | 13 | N02J | 200 | 200 |  | C | SC |  | E | N | EN68 | 1305 | de | LND |  |  |
| EN27130510 |  | CA13 Agitator SK1305 - Check KM drwgs |  | 10d | 2010-11-15 A | 2010-11-29 A | EN27130505 | 100% |  | EN27130510 | EN27130510 | 87B | N02J | 13 | N02J | 200 |  |  |  | LEI |  | E | N | EN27 | 1305 | de | LND |  |  |
| EN281305 |  | CA13 Agitator SK1305 - Shop dwgs(KMD) by Vendor |  | 20d | 2010-11-30 A | 2010-12-28 A | EN27130510, IMS-E-000180 FF, HEN28 FF | 100% |  | EN281305 | EN281305 | 87B | N02J | 13 | N02J | 200 |  |  | E | Chel |  | E | N | EN28 | 1305 | de | LND |  |  |
|  | B | **B Mechanical - Stationary Equipment** |  |  | 2008-12-20 | 2008-12-20 |  |  |  |  |  |  |  |  |  |  |  |  |  |  |  |  |  |  |  |  |  |  |  |
| EB051305 |  | CA13 AgitatorRemUn - Final Loads for Struc Steel | milestone | 0d | 2008-12-20 A | 2008-12-20 A | E3ALL140, E3J0720 SF | 100% |  | EB051305 | EB051305 | 869 |  | 13 |  | 200 |  |  |  | LND |  | E | B | EB05 | 1305 | 3 | LND |  |  |
|  | M | **M Mechanical - Rotating Equipment** |  |  | 2008-11-04 | 2008-11-04 |  |  |  |  |  |  |  |  |  |  |  |  |  |  |  |  |  |  |  |  |  |  |  |
| EM051305 |  | CA13 AgitatorRemUn - Final Loads for Struc Steel | milestone | 0d | 2008-11-04 A | 2008-11-04 A | E3M1120 FF | 100% |  | EM051305 | EM051305 | 867 |  | 13 |  | 200 |  |  |  | LND |  | E | M | EM05 | 1305 | I | LND |  |  |
|  | 1321 | **1321 Catalyst Building Line 2 - CA13** |  |  | 2008-03-03 | 2011-04-08 |  |  |  |  |  |  |  |  |  |  |  |  |  |  |  |  |  |  |  |  |  |  |  |
|  | 0B | **0B General Activities** |  |  | 2009-01-03 | 2009-01-03 |  |  |  |  |  |  |  |  |  |  |  |  |  |  |  |  |  |  |  |  |  |  |  |
| E0201321 |  | CA13 Catalyst Bldg - freeze construction concept | milestone | 0d | 2009-01-03 A | 2009-01-03 A | F3600 | 100% |  | E0201321 | E0201321 | 87A |  | 13 |  | 200 |  |  | E |  |  | E | 0B | E020 | 1321 | INS | LND |  |  |
|  | C | **C Civil** |  |  | 2008-03-03 | 2011-03-04 |  |  |  |  |  |  |  |  |  |  |  |  |  |  |  |  |  |  |  |  |  |  |  |
| EC421321 |  | CA13 Catalyst Bldg - Building Concept |  | 171d | 2008-03-03 A | 2008-11-04 A | F2760 | 100% |  | EC421321 | EC421321 | 87A |  | 13 |  | 200 |  |  |  | LND |  | E | C | EC42 | 1321 | cq | LND |  |  |
| EC241321 |  | CA13 Catalyst Bldg - Foundation Data Sheets Eqpt |  | 128d | 2009-02-25 A | 2009-08-28 A | ER161321, EB051321, EM051321 | 100% |  | EC241321 | EC241321 | 87A |  | 13 |  | 200 |  |  |  | LND |  | E | C | EC24 | 1321 | de | LND |  |  |
| EC221321 |  | CA13 Catalyst Bldg - Civil Foundation Loads Bldg |  | 20d | 2009-12-15 A | 2010-01-15 A | EE46132108, EC241321 FF, ER161321, EJ46132108 | 100% |  | EC221321 | EC221321 | 87A |  | 13 |  | 200 | 200 |  | E | LND |  | E | C | EC22 | 1321 | de | LND |  |  |
| EC441321 |  | CA13 Catalyst Bldg - Building Layout drwgs IFD |  | 20d | 2009-12-15 A | 2010-01-15 A | EC421321, EC221321 FF, AD2230 FF+30d, E0201321 | 100% |  | EC441321 | EC441321 | 87A |  | 13 |  | 200 |  |  |  | LND |  | E | C | EC44 | 1321 | de | LND |  | 1306C01 |
| EC131321 |  | CA13 Catalyst Bldg - Fire Safety Survey Report |  | 171d | 2010-01-18 A | 2010-09-17 A | EC461321 SS | 100% |  | EC131321 | EC131321 | 87A |  | 13 |  | 200 |  |  |  | IPR |  | E | C | EC13 | 1321 | de | LND |  | 1306C15 |
| EC45132105 |  | CA13 Catalyst Bldg - Building Layout drwgs AFC |  | 172d | 2010-01-18 A | 2010-09-20 A | P3C0BD FS+15d, IMS-E-000170 FF, EH241321 FF, AD2230, EC461321 SS, HEC45B FF, EC441321, EC131321 FF, EC48100 | 100% |  | EC45132105 | EC45132105 | 87A |  | 13 |  | 200 |  |  | E | IPR |  | E | C | EC45 | 1321 | ar | LND |  | 1306C13 |
| EC461321 |  | CA13 Catalyst Bldg - Civil Static Calc Bldg |  | 192d | 2010-01-18 A | 2010-10-18 A | P3C0BD FS+15d, EC261301 SS+5d | 100% |  | EC461321 | EC461321 | 87A |  | 13 |  | 200 |  |  |  | IPR |  | E | C | EC46 | 1321 | de | LND |  | 1306C14 |
| EC151321 |  | CA13 Catalyst Bldg - Piling drwgs AFC |  | 44d | 2010-02-08 A | 2010-04-12 A | EC461321 SS+15d, EC131321 SS+10d | 100% |  | EC151321 | EC151321 | 87A |  | 13 |  | 200 |  |  |  | IPR |  | E | C | EC15 | 1321 | PI | LND |  | 1306C16 |
| EC48132103 |  | CA13 Catalyst Bldg - Formw/Reinf drwgs Found. AFC |  | 98d | 2010-02-26 A | 2010-07-19 A | HEC48B FF, EC151321 SS+14d | 100% |  | EC48132103 | EC48132103 | 87A |  | 13 |  | 200 | 200 |  | E | IPR |  | E | C | EC48 | 1321 | ar | LND |  | 1306C21 |
| EC48132105 |  | CA13 Catalyst Bldg - Formw/Reinf drwgs GF +0,00 AFC |  | 117d | 2010-03-12 A | 2010-08-27 A | EH241321 FF, EC48132103 SS+10d, EC461321 SS+20d, HEC48S FF | 100% |  | EC48132105 | EC48132105 | 87A |  | 13 |  | 200 | 200 |  | E | IPR |  | E | C | EC48 | 1321 | ar | LND |  | 1306C22 |
| EC48132110 |  | CA13 Catalyst Bldg - Formw/Reinf drwgs +6,00 AFC |  | 156d | 2010-03-29 A | 2010-11-05 A | EH241321 FF, EC48132105 FF+20d | 100% |  | EC48132110 | EC48132110 | 87A |  | 13 |  | 200 | 200 |  | E | IPR |  | E | C | EC48 | 1321 | ar | LND |  | 1306C23 |
| EC281321 |  | CA13 Catalyst Bldg - Formw/Reinf drwgs EqptFdtn AFC |  | 64d | 2010-04-19 A | 2010-07-19 A | EC48132105 FF | 100% |  | EC281321 | EC281321 | 87A |  | 13 |  | 200 |  |  |  | IPR |  | E | C | EC28 | 1321 | cq | LND |  |  |
| EC48132115 |  | CA13 Catalyst Bldg - Formw/Reinf drwgs +13,70 AFC |  | 142d | 2010-05-06 A | 2010-11-24 A | EC48132110 FF+5d | 100% |  | EC48132115 | EC48132115 | 87A |  | 13 |  | 200 | 200 |  | E | IPR |  | E | C | EC48 | 1321 | ar | LND |  | 1306C24 |
| EC701321 |  | CA13 Catalyst Bldg - Structural Steel KM drwgs |  | 211d | 2010-05-07 A | 2011-03-04 A | EC48132115 SS+1d, EC45132105 FF | 100% |  | EC701321 | EC701321 | 87A | N02$ | 13 | N02$ | 200 |  |  |  | IPR |  | E | C | EC70 | 1321 | de | LND |  | 1306N51 |
| EC48132120 |  | CA13 Catalyst Bldg - Formw/Reinf drwgs Roof AFC |  | 137d | 2010-05-14 A | 2010-11-24 A | EC48132115 FF | 100% |  | EC48132120 | EC48132120 | 87A |  | 13 |  | 200 | 200 |  | E | IPR |  | E | C | EC48 | 1321 | ar | LND |  | 1306C25 |
| EC501321 |  | CA13 Catalyst Bldg - Architec.Detail drwgs Bldg AFC |  | 134d | 2010-07-15 A | 2011-01-21 A | EC48132115 FF, HEC50 FF, EC48132120 FF, EC281321 FF | 100% |  | EC501321 | EC501321 | 87A |  | 13 |  | 200 | 200 |  | E | IPR |  | E | C | EC50 | 1321 | ar | LND |  | 1306C41 |
| EC45132110 |  | CA13 Catalyst Bldg - Building Layout drwgs IFC | milestone | 0d | 2010-07-30 A | 2010-07-30 A | EC45132105 FF-12d | 100% |  | EC45132110 | EC45132110 | 87A |  | 13 |  | 200 |  |  | E | IPR |  | E | C | EC45 | 1321 | ar | LND |  |  |
| EC45132115 |  | CA13 Catalyst Bld - Review Building Layout drwgs |  | 10d | 2010-09-01 A | 2010-09-14 A | EC45132110 | 100% |  | EC45132115 | EC45132115 | 87A |  | 13 |  | 200 |  |  | E | LND |  | E | C | EC45 | 1321 | ar | LND |  |  |

Notes:
- EC421321: P3 Activity Log Info: fixed Layout
- EC221321: P3 Activity Log Info: TKB-B Keyplan to Subcontractor
- EC441321: P3 Activity Log Info: incl. PMT approval
- EC45132105: P3 Activity Log Info: incl. PMT approval
- EC45132110: P3 Activity Log Info: incl. PMT approval
- EC45132115: P3 Activity Log Info: incl. PMT approval

| ID | WBS | Activity | Type | Duration | Start | Finish | Predecessors | Complete | Planned start | Planned finish | Resources | UDF_SAVE ACTID | UDF_SAVE ACT ID | Department | Type of Work | Constr. Area | Inquiry/Order No | PMT-Area | PMT-Respons. | WBS Phase | WBS Discipline | WBS Type of Work | WBS Objects | IMS | UPT | PMT-Phase | PMT-Schedule Org | PMT-Discipline | TB26 Ressource Budget | Pro Unit/DocCode |
| --- | --- | --- | --- | --- | --- | --- | --- | --- | --- | --- | --- | --- | --- | --- | --- | --- | --- | --- | --- | --- | --- | --- | --- | --- | --- | --- | --- | --- | --- | --- |
|  | N | **N Structural Steel** |  |  | 2011-03-07 | 2011-04-08 |  |  |  |  |  |  |  |  |  |  |  |  |  |  |  |  |  |  |  |  |  |  |  |  |
| EN271321 |  | CA13 Catalyst Bldg SK1306 - Check KM drwgs |  | 5d | 2011-03-07 A | 2011-03-11 A | EC701321 | 100% |  |  |  | EN271321 | EN271321 | 87B | N02$ | 13 | N02$ | 200 | LEI | E | N | EN27 | 1321 | de | LND |  |  |  |  |  |
| EN281321 |  | CA13 Catalyst Bldg SK1306 - Shop dwgs(KMD) by Vendor |  | 20d | 2011-03-14 A | 2011-04-08 A | EN271321 | 100% |  |  |  | EN281321 | EN281321 | 87B | N02$ | 13 | N02$ | 200 | Chel | E | N | EN28 | 1321 | de | LND | E |  |  |  |  |
|  | H | **H HVAC** |  |  | 2008-11-24 | 2010-09-03 |  |  |  |  |  |  |  |  |  |  |  |  |  |  |  |  |  |  |  |  |  |  |  |  |
| EH201321 |  | CA13 Catalyst Bldg - HVAC&Plumbing / Feed/Basic |  | 165d | 2008-11-24 A | 2009-07-24 A | AD2230 FF+20d | 100% |  |  |  | EH201321 | EH201321 | 87C |  | 13 |  | 200 | LND | E | H | EH20 | 1321 | OTH | LND | E | 200 | 035 |  |  |
| EH30132105 |  | CA13 Catalyst Bldg - HVAC Layouts Dwgs AFC |  | 142d | 2010-01-11 A | 2010-08-02 A | EH201321, HEH30 FF, P3C0BD FS+15d | 100% |  |  | TKB-H [480 h] | EH30132105 | EH30132105 | 87C |  | 13 |  | 200 | IPR | E | H | EH30 | 1321 | OTH | LND | E | 200 | 035 | 480,00 | 1306H23 |
| EH40132105 |  | CA13 Catalyst Bldg- HVAC Calculations&Flow Diagrams |  | 141d | 2010-01-11 A | 2010-07-30 A | EH30132105 SS | 100% |  |  | TKB-H [320 h] | EH40132105 | EH40132105 | 87C |  | 13 |  | 200 | IPR | E | H | EH40 | 1321 | OTH | LND | E | 200 | 035 | 320,00 | 1306H22 |
| EH071321 |  | CA13 Catalyst Bldg - Issue of Dwgs&Doc's by RDI | level of effort | 92d | 2010-03-19 A | 2010-08-02 A | EH30132105 SS+50d, EH30132105 FF, EH40132110 FF | 100% | 2010-03-22 | 2010-08-02 | TKB-H [3544 h] | EH071321 | EH071321 | 87C |  | 13 |  | 200 | IPR | E | H | EH30 | 1321 | OTH | LND | E | 200 | 035 | 3544,00 |  |
| EH40132110 |  | CA13 Catalyst Bldg - HVAC Calc./Diagrams IFC | milestone | 0d | 2010-03-26 A | 2010-03-26 A | EH40132105 FF-15d | 100% |  |  |  | EH40132110 | EH40132110 | 87C |  | 13 |  | 200 | IPR | E | H | EH40 | 1321 | OTH | LND | E | 200 | 035 |  |  |
| EH30132115 |  | CA13 Catalyst Bldg - Review HVAC Layout Dwgs |  | 90d | 2010-04-29 A | 2010-09-03 A | EH30132110 | 100% |  |  | TKB-H [320 h] | EH30132115 | EH30132115 | 87C |  | 13 |  | 200 | LND | E | H | EH30 | 1321 | OTH | LND | E | 200 | 035 | 320,00 |  |
| EH30132110 |  | CA13 Catalyst Bldg - HVAC Layouts Dwgs IFC | milestone | 0d | 2010-06-11 A | 2010-06-11 A | EH30132105 FF-21d | 100% |  |  |  | EH30132110 | EH30132110 | 87C |  | 13 |  | 200 | IPR | E | H | EH30 | 1321 | OTH | LND | E | 200 | 035 |  |  |
| EH051321 |  | CA13 Catalyst Bldg -Final Loads f.Civil/StrSteel | milestone | 0d | 2010-08-05 A | 2010-08-05 A | E3H0150 SF, HEH12 FF, EH30132105 FF-9d | 100% |  |  |  | EH051321 | EH051321 | 87C |  | 13 |  | 200 | IPR | E | H | EH12 | 1321 | OTH | LND |  |  |  |  |  |
| EH241321 |  | CA13 Catalyst Bldg - Wall&Floor opening details | milestone | 0d | 2010-08-05 A | 2010-08-05 A | EH051321 FF, HEH24 FF, E3H0150 SF | 100% |  |  |  | EH241321 | EH241321 | 87C |  | 13 |  | 200 | IPR | E | H | EH24 | 1321 | OTH | LND | E | 200 | 035 |  | 1306H21 |
|  | B | **B Mechanical - Stationary Equipment** |  |  | 2009-04-01 | 2009-04-01 |  |  |  |  |  |  |  |  |  |  |  |  |  |  |  |  |  |  |  |  |  |  |  |  |
| EB051321 |  | CA13 Calalyst Bldg - Final Loads for Struc Steel | milestone | 0d | 2009-04-01 A | 2009-04-01 A | E3A0120 SF, E3A1320 SF | 100% |  |  |  | EB051321 | EB051321 | 869 |  | 13 |  | 200 | LND | E | B | EB05 | 1321 | 3 | LND |  |  |  |  |  |
|  | M | **M Mechanical - Rotating Equipment** |  |  | 2009-01-03 | 2009-01-03 |  |  |  |  |  |  |  |  |  |  |  |  |  |  |  |  |  |  |  |  |  |  |  |  |
| EM051321 |  | CA13 Calalyst Bldg - Final Loads for Struc Steel | milestone | 0d | 2009-01-03 A | 2009-01-03 A | E3M0820 FF, E3M1020 FF, E3M0720 FF | 100% |  |  |  | EM051321 | EM051321 | 867 |  | 13 |  | 200 | LND | E | M | EM05 | 1321 | I | LND |  |  |  |  |  |
|  | R | **R Piping** |  |  | 2008-04-01 | 2011-01-07 |  |  |  |  |  |  |  |  |  |  |  |  |  |  |  |  |  |  |  |  |  |  |  |  |
| ER151321 |  | CA13 Catalyst Bldg - Conceptual Piping |  | 169d | 2008-04-01 A | 2008-11-28 A | F2760 | 100% |  |  |  | ER151321 | ER151321 | 876 |  | 13 |  | 200 | LND | E | R | ER15 | 1321 | PL | LND |  |  |  |  |  |
| ER301321 |  | CA13 Catalyst Bldg - CAD Model Piping / Eqpt |  | 517d | 2008-07-01 A | 2010-07-23 A | HER30 FF, ER391321 FF+10d, ER151321 SS | 100% |  |  |  | ER301321 | ER301321 | 876 |  | 13 |  | 200 | LNI | E | R | ER30 | 1321 | PL | LND |  |  |  |  |  |
| ER161321 |  | CA13 Catalyst Bldg - prel Loads for Civil |  | 20d | 2009-01-05 A | 2009-01-30 A | ER151321 FF | 100% |  |  |  | ER161321 | ER161321 | 876 |  | 13 |  | 200 | LND | E | R | ER16 | 1321 | PL | LND |  |  |  |  |  |
| ER361321 |  | CA13 Catalyst Bldg - CAD Model Review 60% |  | 12d | 2009-11-02 A | 2009-11-17 A | F4030 SS | 100% |  |  |  | ER361321 | ER361321 | 876 |  | 13 |  | 200 | LND | E | R | ER36 | 1321 | 2 | LND |  |  |  |  |  |
| ER421321 |  | CA13 Catalyst Bldg - Stress Calculation |  | 98d | 2009-11-16 A | 2010-04-09 A | ER361321 | 100% |  |  |  | ER421321 | ER421321 | 872 |  | 13 |  | 200 | LND | E | R | ER42 | 1321 | PL | LND |  |  |  |  |  |
| ER191321 |  | CA13 Catalyst Bldg - Final Loads for Civil | milestone | 0d | 2010-01-04 A | 2010-01-04 A | EC461321 SF-10d, ER161321 FF, HER19 FF, F4030 FF | 100% |  |  |  | ER191321 | ER191321 | 876 |  | 13 |  | 200 | LNI | E | R | ER19 | 1321 | PL | LND |  |  |  |  |  |
| ER391321 |  | CA13 Catalyst Bldg - CAD Model Review 90% |  | 10d | 2010-06-28 A | 2010-07-09 A | HER39 FF, F4460 FF | 100% |  |  |  | ER391321 | ER391321 | 876 |  | 13 |  | 200 | LND | E | R | ER39 | 1321 | 3 | LND |  |  |  |  |  |
| ER451321 |  | CA13 Catalyst Bldg - Piping Isometrics |  | 45d | 2010-08-16 A | 2010-10-15 A | ER301321 FF+20d, ER421321, ER391321 FS+25d | 100% |  |  |  | ER451321 | ER451321 | 876 |  | 13 |  | 200 | LEI | E | R | ER45 | 1321 | 5 | LND |  |  |  |  |  |
| ER491321 |  | CA13 Catalyst Bldg - Design Check/ Rel.Isos&BOM |  | 70d | 2010-09-29 A | 2011-01-07 A | HER49 FF, ER451321 FF | 100% |  |  |  | ER491321 | ER491321 | 876 |  | 13 |  | 200 | LEI | E | R | ER49 | 1321 | 5 | LND |  |  |  |  |  |

| ID | WBS | Activity | Type | Duration | Start | Finish | Predecessors | Complete | UDF_CONTRACT START DATE | UDF_CONTRACT FINISH DATE | UDF_CONTRACT ITEM | UDF_SAVE ACTID | UDF_SAVE ACT ID | Department | Constr. Area | PMT-Phase | PMT-Respons. | WBS Phase | WBS Discipline | WBS Type of Work | WBS Objects | IMS | UPT | Pro Unit/DocCode | PMT-Area | PMT-Schedule Org | Type of Work | Inquiry/Order No |
| --- | --- | --- | --- | --- | --- | --- | --- | --- | --- | --- | --- | --- | --- | --- | --- | --- | --- | --- | --- | --- | --- | --- | --- | --- | --- | --- | --- | --- |
|  | E | **E Electrical** |  |  | 2008-10-06 | 2010-08-27 |  |  |  |  |  |  |  |  |  |  |  |  |  |  |  |  |  |  |  |  |  |  |
| EE46132105 |  | CA13 Catalyst Bldg -prelimLoads f.Civil/StrSteel |  | 15d | 2008-10-06 A | 2008-10-24 A | F3060 FF | 100% | 2011-05-10 | 2011-11-30 | E-16-07-05 | EE46132105 | EE46132105 | 874 | 13 | E | LND | E | E | EE11 | 1321 | E | LND |  |  |  |  |  |
| EE901321 |  | CA13 Catalyst Bldg - Earthing Details |  | 30d | 2009-06-22 A | 2009-07-31 A | EE901201, HEE90 FF | 100% | 2011-05-10 | 2011-11-30 | E-16-07-05 | EE901321 | EE901321 | 874 | 13 | E | LND | E | E | EE90 | 1321 | E | LND |  |  |  |  |  |
| EE46132108 |  | CA13 Catalyst Bldg -Final Loads f.Civil/StrSteel |  | 20d | 2009-09-28 A | 2009-10-23 A | EE46132105 | 100% | 2011-05-10 | 2011-11-30 | E-16-07-05 | EE46132108 | EE46132108 | 874 | 13 | E | LEI | E | E | EE12 | 1321 | E | LND |  |  |  |  |  |
| EE46132110 |  | CA13 Catalyst Bldg - El. CableTray Layout Pl. / LOP's 1st Issue |  | 162d | 2009-12-07 A | 2010-07-30 A | HEE46 FF, F4030 FF+75d, EE460000 | 100% | 2011-05-10 | 2011-11-30 | E-16-07-05 | EE46132110 | EE46132110 | 874 | 13 | E | LEI | E | E | EE46 | 1321 | E | LND |  |  |  |  |  |
| EE561321 |  | CA13 Catalyst Bldg - Cable Pulling Details |  | 159d | 2009-12-10 A | 2010-07-30 A | HEE46 FF, EE46132110 FF, EE500130 | 100% | 2011-05-10 | 2011-11-30 | E-16-07-05 | EE561321 | EE561321 | 874 | 13 | E | LEI | E | E | EE56 | 1321 | E | LND |  |  |  |  |  |
| EE761321 |  | CA13 Catalyst Bldg - Layout Plan Light.& Sockets 1st Issue |  | 150d | 2010-01-26 A | 2010-08-27 A | HEE76 FF+10d, EC501322 SF+10d, EE000180 | 100% | 2011-05-10 | 2011-11-30 | E-16-07-05 | EE761321 | EE761321 | 874 | 13 | E | LEI | E | E | EE76 | 1321 | E | LND |  |  |  |  |  |
|  | J | **J Instrumentation** |  |  | 2008-10-06 | 2010-11-26 |  |  |  |  |  |  |  |  |  |  |  |  |  |  |  |  |  |  |  |  |  |  |
| EJ46132105 |  | CA13 Catalyst Bldg -prelimLoads f.Civil/StrSteel |  | 15d | 2008-10-06 A | 2008-10-24 A | F3060 FF | 100% |  |  |  | EJ46132105 | EJ46132105 | 86E | 13 | E | LND | E | J | EJ11 | 1321 | I | LND | 999 |  |  |  |  |
| EJ46132108 |  | CA13 Catalyst Bldg -Final Loads f.Civil/StrSteel |  | 10d | 2009-12-01 A | 2009-12-14 A | EJ46132105, HEJ12 FF | 100% |  |  |  | EJ46132108 | EJ46132108 | 86E | 13 | E | LEI | E | J | EJ12 | 1321 | I | LND | 999 |  |  |  |  |
| EJ361321 |  | CA13 Catalyst Bldg - Hook-Up drwgs 1st Issue |  | 90d | 2010-02-03 A | 2010-06-14 A | F4030 FS+50d, HEJ36 FF, A1EJ0080 | 100% |  |  |  | EJ361321 | EJ361321 | 86E | 13 | C | LEI | E | J | EJ36 | 1321 | I | LND | 999 | 200 | 200 |  |  |
| EJ46132110 |  | CA13 Catalyst Bldg - Instr Cable Tray Layout Pl. 1st Issue |  | 106d | 2010-03-01 A | 2010-07-30 A | F4030 FF, EE46132110 FF, F4460, HEJ46 FF | 100% | 2011-05-10 | 2011-08-20 | E-15-01-09 | EJ46132110 | EJ46132110 | 86E | 13 | E | LEI | E | J | EJ41 | 1321 | I | LND | 999 |  |  |  |  |
| EJ321321 |  | CA13 Catalyst Bldg - JB Location drwgs |  | 25d | 2010-07-12 A | 2010-08-13 A | F4030, F4460 FF+25d, HEJ37 FF | 100% |  |  |  | EJ321321 | EJ321321 | 86E | 13 | C | LEI | E | J | EJ37 | 1321 | I | LND | 999 | 200 | 200 |  |  |
| EJ801321 |  | CA13 Catalyst Bldg - Loop Diagrams |  | 70d | 2010-08-20 A | 2010-11-26 A | HEJ80 FF, EJ800010, A1EJ0040 SF | 100% |  |  |  | EJ801321 | EJ801321 | 86E | 13 | E | LEI | E | J | EJ80 | 1321 | I | LND | 999 |  |  |  |  |
|  | 1322 | **1322 Teal Building Line 2 - CA13** |  |  | 2008-03-03 | 2011-03-31 |  |  |  |  |  |  |  |  |  |  |  |  |  |  |  |  |  |  |  |  |  |  |
|  | 0B | **0B General Activities** |  |  | 2009-01-03 | 2009-01-03 |  |  |  |  |  |  |  |  |  |  |  |  |  |  |  |  |  |  |  |  |  |  |
| E0201322 |  | CA13 Teal Bldg - freeze construction concept | milestone | 0d | 2009-01-03 A | 2009-01-03 A | F3600 | 100% |  |  |  | E0201322 | E0201322 | 87A | 13 | E |  | E | 0B | E020 | 1322 | INS | LND |  | 200 |  |  |  |
|  | C | **C Civil** |  |  | 2008-03-03 | 2011-02-18 |  |  |  |  |  |  |  |  |  |  |  |  |  |  |  |  |  |  |  |  |  |  |
| EC421322 |  | CA13 Teal Bldg - Building Concept |  | 171d | 2008-03-03 A | 2008-11-04 A | F2760 | 100% |  |  |  | EC421322 | EC421322 | 87A | 13 |  | LND | E | C | EC42 | 1322 | cq | LND |  | 200 |  |  |  |
| EC241322 |  | CA13 Teal Bldg - Foundation Data Sheets Eqpt / Loads IFD |  | 130d | 2009-02-23 A | 2009-08-28 A | ER161322, EB051322, EM051322 | 100% |  |  |  | EC241322 | EC241322 | 87A | 13 |  | LND | E | C | EC24 | 1322 | de | LND |  | 200 |  |  |  |
| EC221322 |  | CA13 Teal Bldg - Civil Foundation Loads Bldg |  | 20d | 2010-01-04 A | 2010-01-29 A | ER161322, EC241322 FF, EE46132208, EJ46132208 FF | 100% |  |  |  | EC221322 | EC221322 | 87A | 13 | E | LND | E | C | EC22 | 1322 | de | LND |  | 200 | 200 |  |  |
| EC441322 |  | CA13 Teal Bldg - Building Layout drwgs IFD |  | 15d | 2010-01-11 A | 2010-01-29 A | E0201322, EC421322, E3C110 FF, EC221322 FF, AD2230 FF+30d | 100% |  |  |  | EC441322 | EC441322 | 87A | 13 |  | LND | E | C | EC44 | 1322 | de | LND | 1302C01 | 200 |  |  |  |
| EC131322 |  | CA13 Teal Bldg - Fire Safety Survey Report |  | 183d | 2010-02-01 A | 2010-10-19 A | EC461322 SS | 100% |  |  |  | EC131322 | EC131322 | 87A | 13 |  | IPR | E | C | EC13 | 1322 | de | LND | 1302C15 | 200 |  |  |  |
| EC45132205 |  | CA13 Teal Bldg - Building Layout drwgs AFC |  | 144d | 2010-02-01 A | 2010-08-25 A | P3C0BD FS+20d, EC441322, EC461322 SS, EC48100, HEC45B FF, AD2230 | 100% |  |  |  | EC45132205 | EC45132205 | 87A | 13 | E | IPR | E | C | EC45 | 1322 | ar | LND | 1302C13 | 200 |  |  |  |
| EC461322 |  | CA13 Teal Bldg - Civil Static Calc Bldg |  | 175d | 2010-02-01 A | 2010-10-07 A | P3C0BD FS+20d, EC261301 SS+10d, EC441322 | 100% |  |  |  | EC461322 | EC461322 | 87A | 13 |  | IPR | E | C | EC46 | 1322 | de | LND | 1302C14 | 200 |  |  |  |
| EC151322 |  | CA13 Teal Bldg - Piling drwgs AFC |  | 40d | 2010-02-12 A | 2010-04-12 A | EC131322 SS+5d, EC461322 SS+9d | 100% |  |  |  | EC151322 | EC151322 | 87A | 13 |  | IPR | E | C | EC15 | 1322 | PI | LND | 1302C16 | 200 |  |  |  |
| EC48132203 |  | CA13 Teal Bldg - Formw/Reinf drwgs Bldg Found. AFC |  | 101d | 2010-03-08 A | 2010-07-30 A | EC461322 SS+25d, EH241322 FF, HEC48B FF, EC151322 SS+10d | 100% |  |  |  | EC48132203 | EC48132203 | 87A | 13 | E | IPR | E | C | EC48 | 1322 | ar | LND | 1302C21 | 200 | 200 |  |  |
| EC48132205 |  | CA13 Teal Bldg - Formw/Reinf drwgs Bldg GF +0,00 AFC |  | 114d | 2010-03-15 A | 2010-08-25 A | EC45132215, HEC48S FF, EC48132203 FF | 100% |  |  |  | EC48132205 | EC48132205 | 87A | 13 | E | IPR | E | C | EC48 | 1322 | ar | LND | 1302C22 | 200 | 200 |  |  |
| EC281322 |  | CA13 Teal Bldg - Formw/Reinf drwgs EqptFdtn AFC |  | 109d | 2010-03-22 A | 2010-08-25 A | EC48132203 FF | 100% |  |  |  | EC281322 | EC281322 | 87A | 13 |  | IPR | E | C | EC28 | 1322 | cq | LND |  | 200 |  |  |  |
| EC701322 |  | CA13 Teal Bldg SK1302 - Structural Steel KM drwgs |  | 197d | 2010-05-14 A | 2011-02-18 A | EC45132205 FF | 100% |  |  |  | EC701322 | EC701322 | 87A | 13 |  | IPR | E | C | EC70 | 1322 | de | LND | 1302N51 | 200 |  | N02Q | N02Q |
| EC501322 |  | CA13 Teal Bldg - Architec.Detail drwgs Bldg AFC |  | 174d | 2010-05-19 A | 2011-01-21 A | EC48132203 FF+10d, EC281322 FF+10d, HEC50 FF, EC120 FF | 100% |  |  |  | EC501322 | EC501322 | 87A | 13 | E | IPR | E | C | EC50 | 1322 | ar | LND | 1302C41 | 200 | 200 |  |  |
| EC45132210 |  | CA13 Teal Bldg - Building Layout drwgs IFC | milestone | 0d | 2010-09-01 A | 2010-09-01 A | EC45132205 FF-14d | 100% |  |  |  | EC45132210 | EC45132210 | 87A | 13 | E | IPR | E | C | EC45 | 1322 | ar | LND |  | 200 |  |  |  |
| EC45132215 |  | CA13 Teal Bldg - Review Building Layout drwgs |  | 10d | 2010-09-01 A | 2010-09-14 A | EC45132210 | 100% |  |  |  | EC45132215 | EC45132215 | 87A | 13 | E | LND | E | C | EC45 | 1322 | ar | LND |  | 200 |  |  |  |

Notes:
- EC421322: P3 Activity Log Info: fixed Layout
- EC221322: P3 Activity Log Info: TKB-B Keyplan to Subcontractor
- EC441322: P3 Activity Log Info: incl. PMT approval
- EC45132205: P3 Activity Log Info: incl. PMT approval
- EC45132210: P3 Activity Log Info: incl. PMT approval
- EC45132215: P3 Activity Log Info: incl. PMT approval

| ID | WBS | Activity | Type | Duration | Start | Finish | Predecessors | Complete | Resources | UDF_SAVE ACTID | UDF_SAVE ACT ID | Department | Type of Work | Constr. Area | Inquiry/Order No | PMT-Area | PMT-Respons. | WBS Phase | WBS Discipline | WBS Type of Work | WBS Objects | IMS | UPT | PMT-Phase | PMT-Schedule Org | PMT-Discipline | TB26 Ressource Budget | Pro Unit/DocCode |
| --- | --- | --- | --- | --- | --- | --- | --- | --- | --- | --- | --- | --- | --- | --- | --- | --- | --- | --- | --- | --- | --- | --- | --- | --- | --- | --- | --- | --- |
|  | N | **N Structural Steel** |  |  | 2011-02-21 | 2011-03-31 |  |  |  |  |  |  |  |  |  |  |  |  |  |  |  |  |  |  |  |  |  |  |
| EN271322 |  | CA13 Teal Bldg SK1302 - Check KM drwgs |  | 14d | 2011-02-21 A | 2011-03-10 A | EC701322 | 100% |  | EN271322 | EN271322 | 87B | N02Q | 13 | N02Q | 200 | LEI | E | N | EN27 | 1322 | de | LND |  |  |  |  |  |
| EN281322 |  | CA13 Teal Bldg SK1302 - Shop dwgs(KMD) by Vendor |  | 15d | 2011-03-11 A | 2011-03-31 A | EN271322 | 100% |  | EN281322 | EN281322 | 87B | N02Q | 13 | N02Q | 200 | Chel | E | N | EN28 | 1322 | de | LND | E |  |  |  |  |
|  | H | **H HVAC** |  |  | 2008-11-24 | 2010-07-09 |  |  |  |  |  |  |  |  |  |  |  |  |  |  |  |  |  |  |  |  |  |  |
| EH201322 |  | CA13 Teal Bldg - HVAC&Plumbing / Feed/Basic |  | 165d | 2008-11-24 A | 2009-07-24 A | AD2230 FF+20d | 100% |  | EH201322 | EH201322 | 87C |  | 13 |  | 200 | LND | E | H | EH20 | 1322 | OTH | LND | E | 200 | 035 |  |  |
| EH30132205 |  | CA13 Teal Bldg - HVAC Layouts Dwgs AFC |  | 114d | 2010-01-18 A | 2010-06-30 A | EH201322, P3C0BD FS+20d, HEH30 FF | 100% | TKB-H [360 h] | EH30132205 | EH30132205 | 87C |  | 13 |  | 200 | IPR | E | H | EH30 | 1322 | OTH | LND | E | 200 | 035 | 360,00 | 1302H23 |
| EH40132205 |  | CA13 Teal Bldg - HVAC Calculations&Flow Diagrams |  | 114d | 2010-01-18 A | 2010-06-30 A | EH30132205 SS | 100% | TKB-H [240 h] | EH40132205 | EH40132205 | 87C |  | 13 |  | 200 | IPR | E | H | EH40 | 1322 | OTH | LND | E | 200 | 035 | 240,00 | 1302H22 |
| EH071322 |  | CA13 Teal Bldg - Issue of Dwgs&Doc's by RDI | level of effort | 69d | 2010-03-22 A | 2010-06-30 A | EH40132210 FF, EH30132205 FF, EH30132205 SS+45d | 100% | TKB-H [672 h] | EH071322 | EH071322 | 87C |  | 13 |  | 200 | IPR | E | H | EH30 | 1322 | OTH | LND | E | 200 | 035 | 672,00 |  |
| EH40132210 |  | CA13 Teal Bldg - HVAC Calc./Diagrams IFC | milestone | 0d | 2010-04-19 A | 2010-04-19 A | EH40132205 FF-15d | 100% |  | EH40132210 | EH40132210 | 87C |  | 13 |  | 200 | IPR | E | H | EH40 | 1322 | OTH | LND | E | 200 | 035 |  |  |
| EH30132215 |  | CA13 Teal Bldg - Review HVAC Layout Dwgs |  | 53d | 2010-04-26 A | 2010-07-09 A | EH30132210 | 100% | TKB-H [240 h] | EH30132215 | EH30132215 | 87C |  | 13 |  | 200 | LND | E | H | EH30 | 1322 | OTH | LND | E | 200 | 035 | 240,00 |  |
| EH30132210 |  | CA13 Teal Bldg - HVAC Layouts Dwgs IFC | milestone | 0d | 2010-05-11 A | 2010-05-11 A | EH30132205 FF-15d | 100% |  | EH30132210 | EH30132210 | 87C |  | 13 |  | 200 | IPR | E | H | EH30 | 1322 | OTH | LND | E | 200 | 035 |  |  |
| EH051322 |  | CA13 Teal Bldg - Final Loads f.Civil/StrSteel | milestone | 0d | 2010-06-30 A | 2010-06-30 A | HEH12 FF, E3H0150 SF, EH30132205 FF | 100% |  | EH051322 | EH051322 | 87C |  | 13 |  | 200 | IPR | E | H | EH12 | 1322 | OTH | LND |  |  |  |  |  |
| EH241322 |  | CA13 Teal Bldg - Wall&Floor opening details | milestone | 0d | 2010-06-30 A | 2010-06-30 A | E3H0150 SF, EH051322 FF, HEH24 FF | 100% |  | EH241322 | EH241322 | 87C |  | 13 |  | 200 | IPR | E | H | EH24 | 1322 | OTH | LND | E | 200 | 035 |  | 1302H21 |
|  | B | **B Mechanical - Stationary Equipment** |  |  | 2009-04-01 | 2009-04-01 |  |  |  |  |  |  |  |  |  |  |  |  |  |  |  |  |  |  |  |  |  |  |
| EB051322 |  | CA13 Teal Bldg - Final Loads for Civil | milestone | 0d | 2009-04-01 A | 2009-04-01 A | E3A1320 SF, E3A1120 SF | 100% |  | EB051322 | EB051322 | 869 |  | 13 |  | 200 | LND | E | B | EB05 | 1322 | 3 | LND |  |  |  |  |  |
|  | M | **M Mechanical - Rotating Equipment** |  |  | 2009-01-03 | 2009-01-03 |  |  |  |  |  |  |  |  |  |  |  |  |  |  |  |  |  |  |  |  |  |  |
| EM051322 |  | CA13 Teal Bldg - Final Loads for Civil | milestone | 0d | 2009-01-03 A | 2009-01-03 A | E3M0820 FF | 100% |  | EM051322 | EM051322 | 867 |  | 13 |  | 200 | LND | E | M | EM05 | 1322 | I | LND |  |  |  |  |  |
|  | R | **R Piping** |  |  | 2008-04-01 | 2011-01-07 |  |  |  |  |  |  |  |  |  |  |  |  |  |  |  |  |  |  |  |  |  |  |
| ER151322 |  | CA13 Teal Bldg - Conceptual Piping |  | 169d | 2008-04-01 A | 2008-11-28 A | F2760 | 100% |  | ER151322 | ER151322 | 876 |  | 13 |  | 200 | LND | E | R | ER15 | 1322 | PL | LND |  |  |  |  |  |
| ER301322 |  | CA13 Teal Bldg - CAD Model Piping / Eqpt |  | 517d | 2008-07-01 A | 2010-07-23 A | ER151322 SS, HER30 FF, ER391322 FF+10d | 100% |  | ER301322 | ER301322 | 876 |  | 13 |  | 200 | LNI | E | R | ER30 | 1322 | PL | LND |  |  |  |  |  |
| ER161322 |  | CA13 Teal Bldg - prel Loads for Civil |  | 20d | 2009-01-05 A | 2009-01-30 A | ER151322 FF | 100% |  | ER161322 | ER161322 | 876 |  | 13 |  | 200 | LND | E | R | ER16 | 1322 | PL | LND |  |  |  |  |  |
| ER361322 |  | CA13 Teal Bldg - CAD Model Review 60% |  | 12d | 2009-11-02 A | 2009-11-17 A | F4030 SS | 100% |  | ER361322 | ER361322 | 876 |  | 13 |  | 200 | LND | E | R | ER36 | 1322 | 2 | LND |  |  |  |  |  |
| ER421322 |  | CA13 Teal Bldg - Stress Calculation |  | 98d | 2009-11-16 A | 2010-04-09 A | ER361322 | 100% |  | ER421322 | ER421322 | 872 |  | 13 |  | 200 | LND | E | R | ER42 | 1322 | PL | LND |  |  |  |  |  |
| ER191322 |  | CA13 Teal Bldg - Final Loads for Civil | milestone | 0d | 2010-01-18 A | 2010-01-18 A | F4030 FF+5d, ER161322 FF, HER19 FF, EC461322 SF-10d | 100% |  | ER191322 | ER191322 | 876 |  | 13 |  | 200 | LNI | E | R | ER19 | 1322 | PL | LND |  |  |  |  |  |
| ER391322 |  | CA13 Teal Bldg - CAD Model Review 90% |  | 10d | 2010-06-28 A | 2010-07-09 A | HER39 FF, F4460 FF | 100% |  | ER391322 | ER391322 | 876 |  | 13 |  | 200 | LND | E | R | ER39 | 1322 | 3 | LND |  |  |  |  |  |
| ER451322 |  | CA13 Teal Bldg - Piping Isometrics |  | 55d | 2010-08-02 A | 2010-10-15 A | ER421322, ER391322 FS+15d, ER301322 FF+20d | 100% |  | ER451322 | ER451322 | 876 |  | 13 |  | 200 | LEI | E | R | ER45 | 1322 | 5 | LND |  |  |  |  |  |
| ER491322 |  | CA13 Teal Bldg - Design Check/ Rel.Isos&BOM |  | 75d | 2010-09-22 A | 2011-01-07 A | HPR30 FF, HER49 FF, ER451322 FF | 100% |  | ER491322 | ER491322 | 876 |  | 13 |  | 200 | LEI | E | R | ER49 | 1322 | 5 | LND |  |  |  |  |  |

| ID | WBS | Activity | Type | Duration | Start | Finish | Predecessors | Complete | UDF_CONTRACT START DATE | UDF_CONTRACT FINISH DATE | UDF_CONTRACT ITEM | UDF_SAVE ACTID | UDF_SAVE ACT ID | Department | Constr. Area | PMT-Phase | PMT-Respons. | WBS Phase | WBS Discipline | WBS Type of Work | WBS Objects | IMS | UPT | Pro Unit/DocCode | PMT-Area | PMT-Schedule Org |
| --- | --- | --- | --- | --- | --- | --- | --- | --- | --- | --- | --- | --- | --- | --- | --- | --- | --- | --- | --- | --- | --- | --- | --- | --- | --- | --- |
|  | E | **E Electrical** |  |  | 2008-10-06 | 2010-08-27 |  |  |  |  |  |  |  |  |  |  |  |  |  |  |  |  |  |  |  |  |
| EE46132205 |  | CA13 Teal Bldg - prelim Loads f.Civil / StrSteel |  | 15d | 2008-10-06 A | 2008-10-24 A | F3060 FF | 100% | 2011-05-10 | 2011-11-30 | E-16-07-05 | EE46132205 | EE46132205 | 874 | 13 | E | LND | E | E | EE11 | 1322 | E | LND |  |  |  |
| EE901322 |  | CA13 Teal Bldg - Earthing Details |  | 30d | 2009-06-22 A | 2009-07-31 A | HEE90 FF, EE900070, EE901201 | 100% | 2011-05-10 | 2011-11-30 | E-16-07-05 | EE901322 | EE901322 | 874 | 13 | E | LND | E | E | EE90 | 1322 | E | LND |  |  |  |
| EE46132208 |  | CA13 Teal Bldg - Final Loads f.Civil / StrSteel |  | 20d | 2009-12-01 A | 2009-12-30 A | EE46132205 | 100% | 2011-05-10 | 2011-11-30 | E-16-07-05 | EE46132208 | EE46132208 | 874 | 13 | E | LEI | E | E | EE12 | 1322 | E | LND |  |  |  |
| EE46132210 |  | CA13 Teal Bldg - El. CableTray Layout Pl. / LOP's 1st Issue |  | 162d | 2009-12-07 A | 2010-07-30 A | EE460000, F4030 FF+75d, HEE46 FF | 100% | 2011-05-10 | 2011-11-30 | E-16-07-05 | EE46132210 | EE46132210 | 874 | 13 | E | LEI | E | E | EE46 | 1322 | E | LND |  |  |  |
| EE561322 |  | CA13 Teal Bldg - Cable Pulling Details |  | 159d | 2009-12-10 A | 2010-07-30 A | EE46132210 FF, HEE46 FF, EE500130 | 100% | 2011-05-10 | 2011-11-30 | E-16-07-05 | EE561322 | EE561322 | 874 | 13 | E | LEI | E | E | EE56 | 1322 | E | LND |  |  |  |
| EE761322 |  | CA13 Teal Bldg - Layout Plan Light.& Sockets 1st Issue |  | 150d | 2010-01-26 A | 2010-08-27 A | HEE76 FF, EE000180, EC501322 SF+10d, IMS-E-000190 FF | 100% | 2011-05-10 | 2011-11-30 | E-16-07-05 | EE761322 | EE761322 | 874 | 13 | E | LEI | E | E | EE76 | 1322 | E | LND |  |  |  |
|  | J | **J Instrumentation** |  |  | 2008-10-06 | 2010-11-26 |  |  |  |  |  |  |  |  |  |  |  |  |  |  |  |  |  |  |  |  |
| EJ46132205 |  | CA13 Teal Bldg - prelim Loads f.Civil / StrSteel |  | 15d | 2008-10-06 A | 2008-10-24 A | F3060 FF | 100% |  |  |  | EJ46132205 | EJ46132205 | 86E | 13 | E | LND | E | J | EJ11 | 1322 | I | LND | 999 |  |  |
| EJ46132208 |  | CA13 Teal Bldg - Final Loads f.Civil / StrSteel |  | 10d | 2010-01-18 A | 2010-01-29 A | EJ46132205, HEJ12 FF | 100% |  |  |  | EJ46132208 | EJ46132208 | 86E | 13 | E | LEI | E | J | EJ12 | 1322 | I | LND | 999 |  |  |
| EJ361322 |  | CA13 Teal Bldg - Hook-Up drwgs 1st Issue |  | 90d | 2010-02-03 A | 2010-06-14 A | F4030 FS+50d, HEJ36 FF, A1EJ0080 | 100% |  |  |  | EJ361322 | EJ361322 | 86E | 13 | C | LEI | E | J | EJ36 | 1322 | I | LND | 999 | 200 | 200 |
| EJ46132210 |  | CA13 Teal Bldg - Instr Cable Tray Layout Plan 1st Issue |  | 106d | 2010-03-01 A | 2010-07-30 A | HEJ46 FF, EE46132210 FF, F4030 FF, F4460 | 100% |  |  |  | EJ46132210 | EJ46132210 | 86E | 13 | E | LEI | E | J | EJ41 | 1322 | I | LND | 999 |  |  |
| EJ321322 |  | CA13 Teal Bldg - JB Location drwgs |  | 25d | 2010-07-12 A | 2010-08-13 A | HEJ37 FF, F4030, F4460 FF+25d | 100% |  |  |  | EJ321322 | EJ321322 | 86E | 13 | C | LEI | E | J | EJ37 | 1322 | I | LND | 999 | 200 | 200 |
| EJ801322 |  | CA13 Teal Bldg - Loop Diagrams |  | 70d | 2010-08-20 A | 2010-11-26 A | A1EJ0040 SF, HEJ80 FF, EJ800010 | 100% |  |  |  | EJ801322 | EJ801322 | 86E | 13 | E | LEI | E | J | EJ80 | 1322 | I | LND | 999 |  |  |
|  | 1330 | **1330 Other Ground Based Eqpt - CA13** |  |  | 2008-04-01 | 2011-01-07 |  |  |  |  |  |  |  |  |  |  |  |  |  |  |  |  |  |  |  |  |
|  | C | **C Civil** |  |  | 2009-05-04 | 2010-08-06 |  |  |  |  |  |  |  |  |  |  |  |  |  |  |  |  |  |  |  |  |
| EC241330 |  | CA13 OthGrBasedEqpt - Layout Drwg / Loads IFD |  | 20d | 2009-05-04 A | 2009-06-02 A | EB051330, EM051330, ER161330 | 100% |  |  |  | EC241330 | EC241330 | 87A | 13 | E | LND | E | C | EC24 | 1330 | de | LND | 1310C01 | 200 | 200 |
| EC261330 |  | CA13 OthGrBasedEqpt - Civil Static Calc Fdtn |  | 106d | 2010-03-08 A | 2010-08-06 A | EC261301 SS+30d, P3C0BD FS+10d, EC241330 | 100% |  |  |  | EC261330 | EC261330 | 87A | 13 | E | IPR | E | C | EC26 | 1330 | de | LND | 1310C14 | 200 | 200 |
| EC281330 |  | CA13 OthGrBasedEqpt - Formw/Reinf drwgs Fdtn AFC |  | 86d | 2010-03-29 A | 2010-07-30 A | EC120 FF, EC261330 FS+10d | 100% |  |  |  | EC281330 | EC281330 | 87A | 13 | E | IPR | E | C | EC28 | 1330 | cq | LND | 1310C21 | 200 | 200 |
|  | B | **B Mechanical - Stationary Equipment** |  |  | 2008-11-26 | 2008-11-26 |  |  |  |  |  |  |  |  |  |  |  |  |  |  |  |  |  |  |  |  |
| EB051330 |  | CA13 OthGrBasedEqpt - Final Loads for Civil | milestone | 0d | 2008-11-26 A | 2008-11-26 A | E3A0620 SF | 100% |  |  |  | EB051330 | EB051330 | 869 | 13 |  | LND | E | B | EB05 | 1330 | 3 | LND |  | 200 |  |
|  | M | **M Mechanical - Rotating Equipment** |  |  | 2008-09-27 | 2008-09-27 |  |  |  |  |  |  |  |  |  |  |  |  |  |  |  |  |  |  |  |  |
| EM051330 |  | CA13 OthGrBasedEqpt - Final Loads for Civil | milestone | 0d | 2008-09-27 A | 2008-09-27 A | E3M0640 | 100% |  |  |  | EM051330 | EM051330 | 867 | 13 |  | LND | E | M | EM05 | 1330 | I | LND |  | 200 |  |
|  | R | **R Piping** |  |  | 2008-04-01 | 2011-01-07 |  |  |  |  |  |  |  |  |  |  |  |  |  |  |  |  |  |  |  |  |
| ER151330 |  | CA13 OthGrBasedEqpt - Conceptual Piping |  | 169d | 2008-04-01 A | 2008-11-28 A | F2760 | 100% |  |  |  | ER151330 | ER151330 | 876 | 13 |  | LND | E | R | ER15 | 1330 | PL | LND |  | 200 |  |
| ER301330 |  | CA13 OthGrBasedEqpt - CAD Model Piping / Eqpt |  | 517d | 2008-07-01 A | 2010-07-23 A | ER391330 FF+10d, ER151330 SS | 100% |  |  |  | ER301330 | ER301330 | 876 | 13 |  | LNI | E | R | ER30 | 1330 | PL | LND |  | 200 |  |
| ER161330 |  | CA13 OthGrBasedEqpt - prel Loads for Civil |  | 20d | 2009-01-05 A | 2009-01-30 A | ER151330 FF | 100% |  |  |  | ER161330 | ER161330 | 876 | 13 |  | LND | E | R | ER16 | 1330 | PL | LND |  | 200 |  |
| ER361330 |  | CA13 OthGrBasedEqpt - CAD Model Review 60% |  | 12d | 2009-11-02 A | 2009-11-17 A | F4030 SS | 100% |  |  |  | ER361330 | ER361330 | 876 | 13 |  | LND | E | R | ER36 | 1330 | 2 | LND |  | 200 |  |
| ER421330 |  | CA13 OthGrBasedEqpt - Stress Calculation |  | 98d | 2009-11-16 A | 2010-04-09 A | ER361330 | 100% |  |  |  | ER421330 | ER421330 | 872 | 13 |  | LND | E | R | ER42 | 1330 | PL | LND |  | 200 |  |
| ER191330 |  | CA13 OthGrBasedEqpt - Final Loads for Civil | milestone | 0d | 2010-02-08 A | 2010-02-08 A | EC261330 SF-10d, ER161330 FF, HER19 FF, F4030 FF+5d | 100% |  |  |  | ER191330 | ER191330 | 876 | 13 |  | LNI | E | R | ER19 | 1330 | PL | LND |  | 200 |  |
| ER391330 |  | CA13 OthGrBasedEqpt - CAD Model Review 90% |  | 10d | 2010-06-28 A | 2010-07-09 A | F4460 FF | 100% |  |  |  | ER391330 | ER391330 | 876 | 13 |  | LND | E | R | ER39 | 1330 | 3 | LND |  | 200 |  |
| ER451330 |  | CA13 OthGrBasedEqpt - Piping Isometrics |  | 55d | 2010-08-02 A | 2010-10-15 A | ER421330, ER301330 FF+20d, E3R100 FF, ER391330 FS+15d | 100% |  |  |  | ER451330 | ER451330 | 876 | 13 |  | LEI | E | R | ER45 | 1330 | 5 | LND |  | 200 |  |
| ER491330 |  | CA13 OthGrBasedEqpt - Design Check/ Rel.Isos&BOM |  | 75d | 2010-09-22 A | 2011-01-07 A | ER451330 FF | 100% |  |  |  | ER491330 | ER491330 | 876 | 13 |  | LEI | E | R | ER49 | 1330 | 5 | LND |  | 200 |  |

| ID | WBS | Activity | Type | Duration | Start | Finish | Predecessors | Complete | UDF_CONTRACT START DATE | UDF_CONTRACT FINISH DATE | UDF_CONTRACT ITEM | UDF_SAVE ACTID | UDF_SAVE ACT ID | Department | Constr. Area | PMT-Phase | PMT-Respons. | WBS Phase | WBS Discipline | WBS Type of Work | WBS Objects | IMS | UPT | Pro Unit/DocCode | PMT-Area | PMT-Schedule Org | UDF_Actictity Name (Russia) | Zeigen/n. Zeigen |
| --- | --- | --- | --- | --- | --- | --- | --- | --- | --- | --- | --- | --- | --- | --- | --- | --- | --- | --- | --- | --- | --- | --- | --- | --- | --- | --- | --- | --- |
|  | E | **E Electrical** |  |  | 2009-05-07 | 2010-07-30 |  |  |  |  |  |  |  |  |  |  |  |  |  |  |  |  |  |  |  |  |  |  |
| EE901330 |  | CA13 OthGrBasedEqpt - Earthing Details |  | 30d | 2009-05-07 A | 2009-06-19 A | EE901201 SS | 100% | 2011-05-10 | 2011-11-30 | E-16-07-05 | EE901330 | EE901330 | 874 | 13 | E | LND | E | E | EE90 | 1330 | E | LND |  |  |  |  |  |
| EE46133010 |  | CA13 OthGrBasedEqpt - El. CableTray Layout Pl. / LOP's 1st Issue |  | 162d | 2009-12-07 A | 2010-07-30 A | EE460000, F4030 FF+75d | 100% | 2011-05-10 | 2011-11-30 | E-16-07-05 | EE46133010 | EE46133010 | 874 | 13 | E | LEI | E | E | EE46 | 1330 | E | LND |  |  |  |  |  |
| EE561330 |  | CA13 OthGrBasedEqpt - Cable Pulling Details |  | 159d | 2009-12-10 A | 2010-07-30 A | EE500130, EE46133010 FF | 100% | 2011-05-10 | 2011-11-30 | E-16-07-05 | EE561330 | EE561330 | 874 | 13 | E | LEI | E | E | EE56 | 1330 | E | LND |  |  |  |  |  |
|  | J | **J Instrumentation** |  |  | 2010-02-03 | 2010-11-26 |  |  |  |  |  |  |  |  |  |  |  |  |  |  |  |  |  |  |  |  |  |  |
| EJ361330 |  | CA13 OthGrBasedEqpt - Hook-Up drwgs 1st Issue |  | 90d | 2010-02-03 A | 2010-06-14 A | F4030 FS+50d, A1EJ0080 | 100% |  |  |  | EJ361330 | EJ361330 | 86E | 13 | C | LEI | E | J | EJ36 | 1330 | I | LND | 999 | 200 | 200 |  |  |
| EJ46133010 |  | CA13 OthGrBasedEqpt - Instr CableTray Layout Pl. 1st Issue |  | 106d | 2010-03-01 A | 2010-07-30 A | EE46133010 FF, F4460, F4030 FF | 100% |  |  |  | EJ46133010 | EJ46133010 | 86E | 13 | E | LEI | E | J | EJ41 | 1330 | I | LND | 999 |  |  |  |  |
| EJ321330 |  | CA13 OthGrBasedEqpt - JB Location drwgs |  | 25d | 2010-07-12 A | 2010-08-13 A | F4460 FF+25d, F4030 | 100% |  |  |  | EJ321330 | EJ321330 | 86E | 13 | C | LEI | E | J | EJ37 | 1330 | I | LND | 999 | 200 | 200 |  |  |
| EJ801330 |  | CA13 OthGrBasedEqpt - Loop Diagrams |  | 70d | 2010-08-20 A | 2010-11-26 A | A1EJ0040 SF, EJ800010 | 100% |  |  |  | EJ801330 | EJ801330 | 86E | 13 | E | LEI | E | J | EJ80 | 1330 | I | LND | 999 |  |  |  |  |
|  | 1332 | **1332 Recycle Gas Compressor - CA13** |  |  | 2008-04-01 | 2011-01-07 |  |  |  |  |  |  |  |  |  |  |  |  |  |  |  |  |  |  |  |  |  |  |
|  | C | **C Civil** |  |  | 2009-01-02 | 2010-09-30 |  |  |  |  |  |  |  |  |  |  |  |  |  |  |  |  |  |  |  |  |  |  |
| EC241332 |  | CA13 R.G.Compressor - Layout Drwg / Loads IFD |  | 20d | 2009-01-02 A | 2009-01-29 A | EM051332, ER161332 | 100% |  |  |  | EC241332 | EC241332 | 87A | 13 |  | LND | E | C | EC24 | 1332 | de | LND | 1311C01 | 200 |  |  |  |
| EC151332 |  | CA13 R.G.Compressor - Piling drwgs AFC |  | 40d | 2010-02-15 A | 2010-04-13 A | EC151301 FF, EC261332 SS | 100% |  |  |  | EC151332 | EC151332 | 87A | 13 |  | IPR | E | C | EC15 | 1332 | PI | LND | 1311C16 | 200 |  |  |  |
| EC261332 |  | CA13 R.G.Compressor - Civil Static Calc EqptFdtn |  | 155d | 2010-02-22 A | 2010-09-30 A | P3C0BD FS+10d, EC241332 | 100% |  |  |  | EC261332 | EC261332 | 87A | 13 |  | IPR | E | C | EC26 | 1332 | de | LND | 1311C14 | 200 |  |  |  |
| EC281332 |  | CA13 R.G.Compressor - Formw/Reinforce drwgs AFC |  | 101d | 2010-03-16 A | 2010-08-09 A | EC151332 SS+10d, EC261332 SS+20d | 100% |  |  |  | EC281332 | EC281332 | 87A | 13 |  | IPR | E | C | EC28 | 1332 | cq | LND | 1311C21 | 200 |  |  |  |
|  | M | **M Mechanical - Rotating Equipment** |  |  |  |  |  |  |  |  |  |  |  |  |  |  |  |  |  |  |  |  |  |  |  |  |  |  |
|  | R | **R Piping** |  |  | 2008-04-01 | 2011-01-07 |  |  |  |  |  |  |  |  |  |  |  |  |  |  |  |  |  |  |  |  |  |  |
| ER151332 |  | CA13 R.G.Compressor - Conceptual Piping |  | 169d | 2008-04-01 A | 2008-11-28 A | F2760 | 100% |  |  |  | ER151332 | ER151332 | 876 | 13 |  | LND | E | R | ER15 | 1332 | PL | LND |  | 200 |  |  |  |
| ER301332 |  | CA13 R.G.Compressor - CAD Model Piping / Eqpt |  | 517d | 2008-07-01 A | 2010-07-23 A | ER391332 FF+10d, ER151332 SS | 100% |  |  |  | ER301332 | ER301332 | 876 | 13 |  | LNI | E | R | ER30 | 1332 | PL | LND |  | 200 |  |  |  |
| ER161332 |  | CA13 R.G.Compressor - prel Loads for Civil |  | 20d | 2009-01-05 A | 2009-01-30 A | ER151332 FF | 100% |  |  |  | ER161332 | ER161332 | 876 | 13 |  | LND | E | R | ER16 | 1332 | PL | LND |  | 200 |  |  |  |
| ER361332 |  | CA13 R.G.Compressor - CAD Model Review 60% |  | 12d | 2009-11-02 A | 2009-11-17 A | F4030 SS | 100% |  |  |  | ER361332 | ER361332 | 876 | 13 |  | LND | E | R | ER36 | 1332 | 2 | LND |  | 200 |  |  |  |
| ER421332 |  | CA13 R.G.Compressor - Stress Calculation |  | 98d | 2009-11-16 A | 2010-04-09 A | ER361332, HER42 FF | 100% |  |  |  | ER421332 | ER421332 | 872 | 13 |  | LND | E | R | ER42 | 1332 | PL | LND |  | 200 |  |  |  |
| HER42 |  | Stress Calculations | level of effort | 98d | 2009-11-16 A | 2010-04-09 A | ER425501 SS, ER425502 SS, ER425402 SS, ER425401 SS | 100% |  |  |  | HER42 | HER42 | 873 | 13 |  | LND | E | R | ER00 | 1332 | 1 | LND |  | 200 |  | Расчет напряжений | L2 |
| ER191332 |  | CA13 R.G.Compressor - Final Loads for Civil | milestone | 0d | 2010-02-01 A | 2010-02-01 A | F4030 SF+20d, EC261332 SF-10d, ER161332 FF | 100% |  |  |  | ER191332 | ER191332 | 876 | 13 |  | LNI | E | R | ER19 | 1332 | PL | LND |  | 200 |  |  |  |
| ER391332 |  | CA13 R.G.Compressor - CAD Model Review 90% |  | 10d | 2010-06-28 A | 2010-07-09 A | F4460 FF | 100% |  |  |  | ER391332 | ER391332 | 876 | 13 |  | LND | E | R | ER39 | 1332 | 3 | LND |  | 200 |  |  |  |
| ER451332 |  | CA13 R.G.Compressor - Piping Isometrics |  | 117d | 2010-07-12 A | 2010-12-22 A | ER301332 FF+20d, ER391332 FF+30d, ER421332 | 100% |  |  |  | ER451332 | ER451332 | 876 | 13 |  | LEI | E | R | ER45 | 1332 | 5 | LND |  | 200 |  |  |  |
| ER491332 |  | CA13 R.G.Compressor - Design Check/ Rel.Isos&BOM |  | 80d | 2010-09-15 A | 2011-01-07 A | ER451332 FF | 100% |  |  |  | ER491332 | ER491332 | 876 | 13 |  | LEI | E | R | ER49 | 1332 | 5 | LND |  | 200 |  |  |  |

| ID | WBS | Activity | Type | Duration | Start | Finish | Predecessors | Complete | Constraint | Resources | Cost | Actual cost | UDF_CONTRACT START DATE | UDF_CONTRACT FINISH DATE | UDF_CONTRACT ITEM | UDF_SAVE ACTID | UDF_SAVE ACT ID | Department | Constr. Area | PMT-Phase | PMT-Respons. | WBS Phase | WBS Discipline | WBS Type of Work | WBS Objects | IMS | UPT | Pro Unit/DocCode | PMT-Area | PMT-Schedule Org | Type of Work | Inquiry/Order No | PMT-Discipline | PMT-Doc. Type | Zeigen/n. Zeigen | TB26 Ressource Budget |
| --- | --- | --- | --- | --- | --- | --- | --- | --- | --- | --- | --- | --- | --- | --- | --- | --- | --- | --- | --- | --- | --- | --- | --- | --- | --- | --- | --- | --- | --- | --- | --- | --- | --- | --- | --- | --- |
|  | E | **E Electrical** |  |  | 2009-05-07 | 2010-07-30 |  |  |  |  |  |  |  |  |  |  |  |  |  |  |  |  |  |  |  |  |  |  |  |  |  |  |  |  |  |  |
| EE901332 |  | CA13 R.G.Compressor - Earthing Details |  | 30d | 2009-05-07 A | 2009-06-19 A | EE901201 SS | 100% |  |  |  |  | 2011-05-10 | 2011-11-30 | E-16-07-05 | EE901332 | EE901332 | 874 | 13 | E | LND | E | E | EE90 | 1332 | E | LND |  |  |  |  |  |  |  |  |  |
| EE46133210 |  | CA13 R.G.Compressor - El. CableTray Layout Pl. / LOP's 1st Issue |  | 162d | 2009-12-07 A | 2010-07-30 A | EE460000, F4030 FF+75d | 100% |  |  |  |  | 2011-05-10 | 2011-11-30 | E-16-07-05 | EE46133210 | EE46133210 | 874 | 13 | E | LEI | E | E | EE46 | 1332 | E | LND |  |  |  |  |  |  |  |  |  |
| EE561332 |  | CA13 R.G.Compressor - Cable Pulling Details |  | 159d | 2009-12-10 A | 2010-07-30 A | EE46133210 FF, EE500130 | 100% |  |  |  |  | 2011-05-10 | 2011-11-30 | E-16-07-05 | EE561332 | EE561332 | 874 | 13 | E | LEI | E | E | EE56 | 1332 | E | LND |  |  |  |  |  |  |  |  |  |
|  | J | **J Instrumentation** |  |  | 2010-02-03 | 2010-11-26 |  |  |  |  |  |  |  |  |  |  |  |  |  |  |  |  |  |  |  |  |  |  |  |  |  |  |  |  |  |  |
| EJ361332 |  | CA13 R.G.Compressor - Hook-Up drwgs 1st Issue |  | 90d | 2010-02-03 A | 2010-06-14 A | F4030 FS+50d, A1EJ0080 | 100% |  |  |  |  |  |  |  | EJ361332 | EJ361332 | 86E | 13 | C | LEI | E | J | EJ36 | 1332 | I | LND | 999 | 200 | 200 |  |  |  |  |  |  |
| EJ46133210 |  | CA13 R.G.Compressor - Instr CableTray Layout Pl. 1st Issue |  | 106d | 2010-03-01 A | 2010-07-30 A | EE46133210 FF, F4460, F4030 FF | 100% |  |  |  |  |  |  |  | EJ46133210 | EJ46133210 | 86E | 13 | E | LEI | E | J | EJ41 | 1332 | I | LND | 999 |  |  |  |  |  |  |  |  |
| EJ321332 |  | CA13 R.G.Compressor - JB Location drwgs |  | 25d | 2010-07-12 A | 2010-08-13 A | F4460 FF+25d, F4030 | 100% |  |  |  |  |  |  |  | EJ321332 | EJ321332 | 86E | 13 | C | LEI | E | J | EJ37 | 1332 | I | LND | 999 | 200 | 200 |  |  |  |  |  |  |
| EJ801332 |  | CA13 R.G.Compressor - Loop Diagrams |  | 70d | 2010-08-20 A | 2010-11-26 A | EJ800010, A1EJ0040 SF | 100% |  |  |  |  |  |  |  | EJ801332 | EJ801332 | 86E | 13 | E | LEI | E | J | EJ80 | 1332 | I | LND | 999 |  |  |  |  |  |  |  |  |
|  | 14 | **14 CA14 - Flare Area** |  |  | 2008-04-01 | 2011-11-10 |  |  |  |  |  |  |  |  |  |  |  |  |  |  |  |  |  |  |  |  |  |  |  |  |  |  |  |  |  |  |
|  | LUZ2 | **LUZ2 General ( )** |  |  | 2009-03-03 | 2010-10-14 |  |  |  |  |  |  |  |  |  |  |  |  |  |  |  |  |  |  |  |  |  |  |  |  |  |  |  |  |  |  |
|  | B | **B Mechanical - Stationary Equipment** |  |  | 2009-03-03 | 2010-10-14 |  |  |  |  |  |  |  |  |  |  |  |  |  |  |  |  |  |  |  |  |  |  |  |  |  |  |  |  |  |  |
| E3A1805 |  | A18 Flare Package - Concept Phase |  | 14d | 2009-03-03 A | 2009-03-20 A | ES100100 | 100% |  |  |  |  |  |  |  | E3A1805 | E3A1805 | 869 | 14 | E | LND | E | B | EB13 | LUZ2 | 3 | LND |  | 200 | 200 | A18 | 2DD0330 | 055 | DEV | FL |  |
| E3A1810 |  | A18 Flare Package - Inquiry Spec. |  | 21d | 2009-04-27 A | 2009-05-27 A | ES100120 FF, F1670 SS, ES100100, E3A1805 FF, EP20045 SS | 100% |  |  |  |  |  |  |  | E3A1810 | E3A1810 | 869 | 14 | E | LND | E | B | EB13 | LUZ2 | 3 | LND |  | 200 | 200 | A18 | 2DD0330 | 055 | DEV | FL |  |
| E3A1815 |  | A18 Flare Package - Prel.Bid Tab for PMT review | milestone | 0d | 2009-09-17 A | 2009-09-17 A | P3A18E, E3A1820 SS-3d | 100% |  |  |  |  |  |  |  | E3A1815 | E3A1815 | 869 | 14 | E | LND | E | B | EB14 | LUZ2 | 3 | LND |  | 200 | 200 | A18 | 2DD0330 | 055 |  | 0 |  |
| E3A1820 |  | A18 Flare Package - Techn. Eval./PO Spec |  | 151d | 2009-10-02 A | 2010-05-11 A | HEB20 FF, P3A18B FS+88d | 100% |  | TAA [800 h] |  |  |  |  |  | E3A1820 | E3A1820 | 869 | 14 | E | LND | E | B | EB14 | LUZ2 | 2 | LND |  | 200 | 200 | A18 | 2DD0330 | 055 |  |  | 800,00 |
| E3A1830 |  | A18 Flare Package - Techn. Eval./Bid Tab Final. | milestone | 0d | 2009-12-21 A | 2009-12-21 A | E3A1815 SF, E3A1820 FF-27d | 100% |  |  |  |  |  |  |  | E3A1830 | E3A1830 | 869 | 14 | E | LND | E | B | EB14 | LUZ2 | 2 | LND |  | 200 | 200 | A18 | 2DD0330 | 055 |  |  |  |
| E3A1840 |  | A18 Flare Package - 1st Review Vendor dwgs |  | 31d | 2010-06-11 A | 2010-07-23 A | P3A18L SS+30d, HEB50 FF | 100% |  | TAA [2400 h] |  |  |  |  |  | E3A1840 | E3A1840 | 869 | 14 | E | LND | E | B | EB15 | LUZ2 | 3 | LND |  | 200 | 200 | A18 | 2DD0330 | 055 |  |  | 2400,00 |
| E3A1850 |  | A18 Flare Package - Vendor dwgs approved | milestone | 0d | 2010-06-30 A | 2010-06-30 A | E3A1840 FF | 100% |  |  | 436,000 | 436,000 |  |  |  | E3A1850 | E3A1850 | 869 | 14 | E | LND | E | B | EB15 | LUZ2 | 3 | LND |  | 200 | 200 | A18 | 2DD0330 | 055 | DFA |  |  |
| E3A1860 |  | A18 Flare Package - 2nd Review Vendor dwgs |  | 59d | 2010-07-26 A | 2010-10-14 A | P3A18L SS+90d, E3A1850 | 100% |  | TAA [2000 h] |  |  |  |  |  | E3A1860 | E3A1860 | 869 | 14 | E | LND | E | B | EB15 | LUZ2 | 3 | LND |  | 200 | 200 | A18 | 2DD0330 | 055 |  |  | 2000,00 |
|  | 1400 | **1400 Generals - CA14** |  |  | 2010-10-26 | 2011-04-25 |  |  |  |  |  |  |  |  |  |  |  |  |  |  |  |  |  |  |  |  |  |  |  |  |  |  |  |  |  |  |
|  | C | **C Civil** |  |  | 2010-10-26 | 2011-04-25 |  |  |  |  |  |  |  |  |  |  |  |  |  |  |  |  |  |  |  |  |  |  |  |  |  |  |  |  |  |  |
| EC441400 |  | CA14 General - Civil Layout drwgs / Loads IFD | level of effort | 34d | 2010-10-26 A | 2010-12-13 A | EC241130 SS, EC241130 FF | 100% |  |  |  |  |  |  |  | EC441400 | EC441400 | 87A | 13 | E | LND | E | C | EC44 | 1400 | de | LND | 1400C01 | 200 |  |  |  |  |  |  |  |
| EC071405 |  | CA14 General - Issue of working drwgs (AFC) by RDI |  | 93d | 2010-12-14 A | 2011-04-25 A | EC261130 SS, EC281410 FF, EC261410 SS | 100% |  | TKB-B [2160 h] |  |  |  |  |  | EC071405 | EC071405 | 87A | 14 | E | IPR | E | C | EC07 | 1400 | cq | LND | 1010C13 | 200 |  |  | 999 |  |  | FL | 2160,00 |
| EC44140005 |  | CA14 General - General Drwgs & Documents |  | 81d | 2011-01-03 A | 2011-04-25 A | EC45141005 FF | 100% |  |  |  |  |  |  |  | EC44140005 | EC44140005 | 87A | 14 | E | IPR | E | C | EC00 | 1400 | de | LND | 1400C11 | 200 |  |  |  |  |  |  |  |
| EC071400 |  | CA14 General - Check & Release of working drwgs (AFC) |  | 78d | 2011-01-06 A | 2011-04-25 A | EC601400 FF, EC45141005 SS+15d | 100% |  | TKB-B [1032 h] |  |  |  |  |  | EC071400 | EC071400 | 87A | 14 | E | LND | E | C | EC07 | 1400 | cq | LND |  | 200 |  |  | 999 |  |  | FL | 1032,00 |
| EC601400 |  | CA14 General - Paving drwgs AFC |  | 77d | 2011-01-07 A | 2011-04-25 A | EC120 FF, EC281130 FF, EC281410 FF, EC44140005 FF | 100% | start on or after 2011-01-07 |  |  |  |  |  |  | EC601400 | EC601400 | 87A | 14 | E | IPR | E | C | EC60 | 1400 | de | LND | 9614C96 | 200 | 200 |  |  |  |  |  |  |

Notes:
- EE561332: P3 Activity Log Info: UG/Above Ground Details
- E3A1850: Expenses: 900A 436000
- EC441400: P3 Activity Log Info: incl. PMT approval
- EC44140005: P3 Activity Log Info: incl. PMT approval

| ID | WBS | Activity | Type | Duration | Start | Finish | Predecessors | Complete | Constraint | Calendar | Resources | UDF_SAVE ACTID | UDF_SAVE ACT ID | Department | Constr. Area | PMT-Area | PMT-Discipline | PMT-Phase | PMT-Respons. | WBS Phase | WBS Discipline | WBS Type of Work | WBS Objects | IMS | UPT | Pro Unit/DocCode | Zeigen/n. Zeigen | Inquiry/Order No | PMT-Schedule Org | TB26 Ressource Budget | Type of Work |
| --- | --- | --- | --- | --- | --- | --- | --- | --- | --- | --- | --- | --- | --- | --- | --- | --- | --- | --- | --- | --- | --- | --- | --- | --- | --- | --- | --- | --- | --- | --- | --- |
|  | 1410 | **1410 Flare Package - CA14** |  |  | 2009-06-02 | 2011-11-10 |  |  |  |  |  |  |  |  |  |  |  |  |  |  |  |  |  |  |  |  |  |  |  |  |  |
|  | L | **L Plant Design** |  |  | 2010-09-18 | 2011-07-23 |  |  |  |  |  |  |  |  |  |  |  |  |  |  |  |  |  |  |  |  |  |  |  |  |  |
| ER14000 |  | 30% Design Review CA14/53 - Flare Area |  | 1d | 2010-09-18 A | 2010-09-18 A | E3A1850 FF | 100% |  | TB26 - 2 - Manuf and Delivy |  | ER14000 | ER14000 | 876 | 14 | 200 | 050 | AD | LEI | E | L | ER33 | 1410 | 1 | LND |  |  |  |  |  |  |
| ER18000 |  | 30% Design Review CA18 - Chiller Unit Area |  | 1d | 2011-07-23 A | 2011-07-23 A | E3M1820 SS+20d, E3A02D20 SS+20d, E3M1720, ER291810 | 100% |  | TB26 - 2 - Manuf and Delivy |  | ER14000 | ER18000 | 876 | 18 | 200 | 050 | AD | LEI | E | L | ER33 | 1810 | 1 | LND |  |  |  |  |  |  |
|  | C | **C Civil** |  |  | 2010-10-19 | 2011-04-21 |  |  |  |  |  |  |  |  |  |  |  |  |  |  |  |  |  |  |  |  |  |  |  |  |  |
| EC241410 |  | CA14 Flare Package - Layout Drwg / Loads IFD |  | 39d | 2010-10-19 A | 2010-12-13 A | EC441400 FF, EB051410 FF, EN251410 FF, EC24120010 FF | 100% |  |  |  | EC241410 | EC241410 | 87A | 14 | 200 |  | E | LND | E | C | EC24 | 1410 | de | LND | 1401C01 | FL |  |  |  |  |
| EC151410 |  | CA14 Flare Package - Piling drwgs AFC |  | 63d | 2010-12-14 A | 2011-03-14 A | EC261410 SS, EC15120010 FF, IMS-E-000130 FF | 100% | start on or after 2010-12-13 |  |  | EC151410 | EC151410 | 87A | 14 | 200 |  | E | AVR | E | C | EC15 | 1410 | PI | LND | 1401C16 | FL | 2DD0330 |  |  |  |
| EC261410 |  | CA14 Flare Package - Civil Static Calc EqptFdtn |  | 63d | 2010-12-14 A | 2011-03-14 A | EC241410, P3C0BD | 100% | start on or after 2010-12-14 |  |  | EC261410 | EC261410 | 87A | 14 | 200 |  | E | AVR | E | C | EC26 | 1410 | de | LND | 1401C14 | FL | 2DD0330 |  |  |  |
| EC281410 |  | CA14 Flare Package - Formw/Reinforce drwgs AFC |  | 91d | 2010-12-14 A | 2011-04-21 A | EC151410 SS, EC261410 SS | 100% | start on or after 2010-12-14 |  |  | EC281410 | EC281410 | 87A | 14 | 200 |  | E | AVR | E | C | EC28 | 1410 | cq | LND | 1401C21 | FL |  | 200 |  |  |
| EC45141005 |  | CA14 Flare Package - Civil Layout drwgs AFC |  | 91d | 2010-12-14 A | 2011-04-21 A | EC261410 SS, EC241410 | 100% |  |  |  | EC45141005 | EC45141005 | 87A | 14 | 200 |  | E | AVR | E | C | EC45 | 1410 | ar | LND | 1401C13 | FL | 2DD0330 |  |  |  |
| EC45141015 |  | CA14 Flare Package - Review Civil Layout drwgs |  | 10d | 2010-12-30 A | 2011-01-13 A | EC45141010 | 100% |  |  |  | EC45141015 | EC45141015 | 87A | 14 | 200 |  | E | LND | E | C | EC45 | 1410 | ar | LND |  | FL |  |  |  |  |
| EC45141010 |  | CA14 Flare Package - Civil Layout drwgs IFC | milestone | 0d | 2011-02-16 A | 2011-02-16 A | EC45141005 SF+45d | 100% |  |  |  | EC45141010 | EC45141010 | 87A | 14 | 200 |  | E | AVR | E | C | EC45 | 1410 | ar | LND |  | FL |  |  |  |  |
|  | N | **N Structural Steel** |  |  | 2010-09-21 | 2011-05-30 |  |  |  |  |  |  |  |  |  |  |  |  |  |  |  |  |  |  |  |  |  |  |  |  |  |
| EN151410 |  | CA14 Flare/Auxiliary Structures - CAD Model/Concepts StrSteel |  | 25d | 2010-09-21 A | 2010-10-25 A | E3A1850 FF+10d, P3A18B | 100% |  |  | TKB-S [240 h] | EN151410 | EN151410 | 87B | 14 | 200 | 055 | E | LEI | E | N | EN15 | 1410 | de | LND |  | FL | N02Ь | 200 | 240,00 | N02Ь |
| EN21141005 |  | CA14 Flare/Auxiliary Structures - GA-Drwgs + Fdtn Loads |  | 27d | 2010-10-28 A | 2010-12-06 A | EE46141005, EN151410, ER161410, EJ46141005 | 100% |  |  | TKB-S [160 h] | EN21141005 | EN21141005 | 87B | 14 | 200 |  |  | LEI | E | N | EN21 | 1410 | de | LND |  | FL | N02Ь |  | 160,00 | N02Ь |
| EN24141005 |  | CA14 Flare/Auxiliary Structures - StaticCalc f.Fdtn Load |  | 25d | 2010-11-08 A | 2010-12-13 A | EN21141005 FF-6d | 100% |  |  |  | EN24141005 | EN24141005 | 87B | 14 | 200 |  |  | LEI | E | N | EN24 | 1410 | de | LND |  | FL | N02Ь |  |  | N02Ь |
| EN261410 |  | CA14 Flare/Auxiliary Structures - Layout dwgs input for KM dwgs |  | 93d | 2010-11-08 A | 2011-03-21 A | EN24141010 FF, F4045 FF | 100% |  |  | TKB-S [480 h] | EN261410 | EN261410 | 87B | 14 | 200 |  |  | LEI | E | N | EN26 | 1410 | st | LND |  | FL | N02Ь |  | 480,00 | N02Ь |
| EN21141010 |  | CA14 Flare/Auxiliary Structures - GA-Drwgs + Final Loads |  | 41d | 2011-01-03 A | 2011-02-28 A | EJ46141008 FS+20d, EB051410, EE46141008, EN21141005 FF+11d, EN251410 | 100% |  |  | TKB-S [160 h] | EN21141010 | EN21141010 | 87B | 14 | 200 |  |  | LEI | E | N | EN21 | 1410 | de | LND |  | FL | N02Ь |  | 160,00 | N02Ь |
| EN251410 |  | CA14 Flare/Auxiliary Structures - Loads for Civil | milestone | 0d | 2011-01-07 A | 2011-01-07 A | EN24141005 FF | 100% |  |  |  | EN251410 | EN251410 | 87B | 14 | 200 | 055 | E | LEI | E | N | EN25 | 1410 | de | LND |  | FL | N02Ь | 200 |  | N02Ь |
| EN24141010 |  | CA14 Flare/Auxiliary Structures - Final Static Calc |  | 20d | 2011-02-14 A | 2011-03-11 A | EN21141010, ER191410 FF | 100% |  |  |  | EN24141010 | EN24141010 | 87B | 14 | 200 |  |  | LEI | E | N | EN24 | 1410 | de | LND |  | FL | N02Ь |  |  | N02Ь |
| EN671410 |  | CA14 Flare/Auxiliary Structures - Grating Cut-Out drwgs |  | 35d | 2011-03-14 A | 2011-04-29 A | F4468 FF+10d, EN261410 FF+29d | 100% |  |  | TKB-S [240 h] | EN671410 | EN671410 | 87B | 14 | 200 |  | C | LEI | E | N | EN67 | 1410 | de | LND |  | FL | N02Ь | 200 | 240,00 | N02Ь |
| EN27141005 |  | CA14 Flare/Auxiliary Structures - KM drwgs |  | 20d | 2011-03-22 A | 2011-04-18 A | EN24141005, EN261410, E3C170 FF | 100% |  |  | KM Drwgs preparation by Cheljabinsk [36 t] | EN27141005 | EN27141005 | 87B | 14 | 200 |  |  | Chel | E | N | EN27 | 1410 | de | LND |  | FL | N02Ь |  | 0,00 | N02Ь |
| EN681410 |  | CA14 Flare/Auxiliary Structures - Grating Fabrication drwgs |  | 20d | 2011-04-14 A | 2011-05-11 A | EN671410 FF+8d | 100% |  |  |  | EN681410 | EN681410 | 87B | 14 | 200 |  | C | SC | E | N | EN68 | 1410 | de | LND |  | FL | N02Ь | 200 |  | N02Ь |
| EN27141010 |  | CA14 Flare/Auxiliary Structures - Check KM drwgs |  | 10d | 2011-04-19 A | 2011-05-02 A | IMS-E-000120 FF, EN27141005 | 100% |  |  |  | EN27141010 | EN27141010 | 87B | 14 | 200 |  |  | LEI | E | N | EN27 | 1410 | de | LND |  | FL | N02Ь |  |  | N02Ь |
| EN641410 |  | CA14 Flare/Auxiliary Structures - Check Grating Cut-Out drwgs |  | 5d | 2011-05-02 A | 2011-05-06 A | EN671410 | 100% |  |  |  | EN641410 | EN641410 | 87B | 14 | 200 |  | C | LEI | E | N | EN67 | 1410 | de | LND |  |  | N02Ь | 200 |  | N02Ь |
| EN281410 |  | CA14 Flare/Auxiliary Structures - Shop dwgs(KMD) by Vend |  | 20d | 2011-05-03 A | 2011-05-30 A | EN27141010, IMS-E-000180 FF | 100% |  |  |  | EN281410 | EN281410 | 87B | 14 | 200 |  |  | Chel | E | N | EN28 | 1410 | de | LND |  | FL | N02Ь |  |  | N02Ь |

Notes:
- EC45141015: P3 Activity Log Info: incl. PMT approval
- EC45141010: P3 Activity Log Info: incl. PMT approval

| ID | WBS | Activity | Type | Duration | Start | Finish | Predecessors | Complete | Planned start | Planned finish | Total float | Constraint | Resources | UDF_SAVE ACTID | UDF_SAVE ACT ID | Department | Constr. Area | PMT-Area | PMT-Respons. | Zeigen/n. Zeigen | WBS Phase | WBS Discipline | WBS Type of Work | WBS Objects | IMS | UPT | PMT-Phase | TB26 Ressource Budget | Pro Unit/DocCode | PMT-Schedule Org |
| --- | --- | --- | --- | --- | --- | --- | --- | --- | --- | --- | --- | --- | --- | --- | --- | --- | --- | --- | --- | --- | --- | --- | --- | --- | --- | --- | --- | --- | --- | --- |
|  | B | **B Mechanical - Stationary Equipment** |  |  | 2010-09-18 | 2010-09-18 |  |  |  |  |  |  |  |  |  |  |  |  |  |  |  |  |  |  |  |  |  |  |  |  |
| EB051410 |  | CA14 Flare Package - Final Loads for Struc Steel | milestone | 0d | 2010-09-18 A | 2010-09-18 A | ER14000 FF | 100% | 2010-09-17 | 2010-09-17 |  | as late as possible |  | EB051410 | EB051410 | 869 | 14 | 200 | LND | FL | E | B | EB05 | 1410 | 3 | LND |  |  |  |  |
|  | R | **R Piping** |  |  | 2009-06-02 | 2011-11-10 |  |  |  |  |  |  |  |  |  |  |  |  |  |  |  |  |  |  |  |  |  |  |  |  |
| ER151410 |  | CA14 Flare Area - Conceptual Piping |  | 328d | 2009-06-02 A | 2010-09-15 A | F2760 | 100% |  |  |  |  |  | ER151410 | ER151410 | 876 | 14 | 200 | LND | FL | E | R | ER15 | 1410 | PL | LND |  |  |  |  |
| ER301410 |  | CA14 Flare Area - CAD Model Piping / Eqpt |  | 314d | 2009-10-29 A | 2011-01-27 A | ER391410 FF+5d, ER151410 SS | 100% |  |  |  |  |  | ER301410 | ER301410 | 876 | 14 | 200 | LNI | FL | E | R | ER30 | 1410 | PL | LND |  |  |  |  |
| ER161410 |  | CA14 Flare Area - prelim Loads for SteelStruc |  | 20d | 2010-08-19 A | 2010-09-15 A | ER151410 FF | 100% |  |  |  |  |  | ER161410 | ER161410 | 876 | 14 | 200 | LND | FL | E | R | ER16 | 1410 | PL | LND |  |  |  |  |
| ER421410 |  | CA14 Flare Package - Stress Calculation |  | 90d | 2010-12-30 A | 2011-05-05 A | ER361410 FF | 100% |  |  |  | as late as possible |  | ER421410 | ER421410 | 872 | 14 | 200 | LND |  | E | R | ER42 | 1410 | PL | LND |  |  |  |  |
| ER451410 |  | CA14 Flare Package - Piping Isometrics |  | 90d | 2010-12-30 A | 2011-05-05 A | ER301410 FF+10d, ER421410 FF, ER391410 FF | 100% |  |  |  | as late as possible |  | ER451410 | ER451410 | 876 | 14 | 200 | LEI |  | E | R | ER45 | 1410 | 5 | LND |  |  |  |  |
| ER191410 |  | CA14 Flare Package - Final Loads for SteelStruc | milestone | 0d | 2011-01-03 A | 2011-01-03 A | EN21141010 SF-5d, ER161410 FF | 100% |  |  |  |  |  | ER191410 | ER191410 | 876 | 14 | 200 | LNI | FL | E | R | ER19 | 1410 | PL | LND |  |  |  |  |
| ER491410 |  | CA14 Flare Package - Design Check / Rel.Isos&BOM |  | 79d | 2011-01-17 A | 2011-05-05 A | ER451410 FF | 100% |  |  |  |  |  | ER491410 | ER491410 | 876 | 14 | 200 | LEI |  | E | R | ER49 | 1410 | 5 | LND |  |  |  |  |
| ER361410 |  | CA14 Flare Package - CAD Model Review 60% |  | 3d | 2011-01-18 A | 2011-01-20 A | F4045 FF, ER14000 FF+15d | 100% |  |  |  |  |  | ER361410 | ER361410 | 876 | 14 | 200 | LND |  | E | R | ER36 | 1410 | 2 | LND |  |  |  |  |
| ER391410 |  | CA14 Flare Package - CAD Model Review 90% |  | 3d | 2011-01-18 A | 2011-01-20 A | F4468 FF | 100% |  |  |  |  |  | ER391410 | ER391410 | 876 | 14 | 200 | LND | FL | E | R | ER39 | 1410 | 3 | LND |  |  |  |  |
| ER491810 |  | CA18 Chiller Unit Area - Design Check / Rel.Isos&BOM |  | 35d | 2011-09-21 | 2011-11-10 | F4475 FF+10d |  |  |  | 402.5d |  |  | ER491410 | ER491810 | 876 | 14 | 200 | LEI |  | E | R | ER49 | 1410 | 5 | LND |  |  |  |  |
|  | E | **E Electrical** |  |  | 2009-06-22 | 2011-01-18 |  |  |  |  |  |  |  |  |  |  |  |  |  |  |  |  |  |  |  |  |  |  |  |  |
| EE901410 |  | CA14 Flare Package - Earthing Details |  | 30d | 2009-06-22 A | 2009-07-31 A | EE905301 FF | 100% |  |  |  |  |  | EE901410 | EE901410 | 874 | 14 |  | LND | FL | E | E | EE90 | 1410 | E | LND | E |  |  |  |
| EE761410 |  | CA14 Flare Package - Layout Plan Light.&Sockets 1st Issue |  | 249d | 2010-01-26 A | 2011-01-18 A | EE000180 FS+10d | 100% |  |  |  |  |  | EE761410 | EE761410 | 874 | 14 |  | LEI | FL | E | E | EE76 | 1410 | E | LND | E |  |  |  |
| EE46141005 |  | CA14 Flare Package - prelimLoads f.Struc Steel |  | 15d | 2010-08-26 A | 2010-09-15 A | ER14000 FF | 100% |  |  |  |  |  | EE46141005 | EE46141005 | 874 | 14 |  | LND | FL | E | E | EE11 | 1410 | E | LND | E |  |  |  |
| EE46141008 |  | CA14 Flare Package - Final Loads f.Struc Steel |  | 39d | 2010-10-26 A | 2010-12-20 A | EE46141005 | 100% |  |  |  |  |  | EE46141008 | EE46141008 | 874 | 14 |  | LEI | FL | E | E | EE12 | 1410 | E | LND | E |  |  |  |
|  | J | **J Instrumentation** |  |  | 2009-12-21 | 2011-02-21 |  |  |  |  |  |  |  |  |  |  |  |  |  |  |  |  |  |  |  |  |  |  |  |  |
| EJ46141005 |  | CA14 Flare Package - prelim Loads f.Struc Steel |  | 70d | 2009-12-21 A | 2010-04-01 A | F3060 | 100% |  |  |  |  | TAP [1920 h] | EJ46141005 | EJ46141005 | 86E | 14 |  | LND | FL | E | J | EJ11 | 1410 | I | LND | E | 1920,00 | 999 |  |
| EJ801410 |  | CA14 Flare Package - Loop Diagrams |  | 70d | 2010-08-20 A | 2010-11-26 A | EJ800010, A1EJ0040 SF | 100% |  |  |  |  |  | EJ801410 | EJ801410 | 86E | 14 |  | LEI | FL | E | J | EJ80 | 1410 | I | LND | E |  | 999 |  |
| EJ46141008 |  | CA14 Flare Package - Final Loads f.Struc Steel |  | 10d | 2010-10-12 A | 2010-10-25 A | EJ46141005 | 100% |  |  |  |  |  | EJ46141008 | EJ46141008 | 86E | 14 |  | LEI | FL | E | J | EJ12 | 1410 | I | LND | E |  | 999 |  |
| EJ361410 |  | CA14 Flare Package - Hook-Up drwgs |  | 84d | 2010-10-22 A | 2011-02-21 A | EJ360000 FF, F4045 FF+10d | 100% |  |  |  |  |  | EJ361410 | EJ361410 | 86E | 14 | 200 | LEI | FL | E | J | EJ36 | 1410 | I | LND | C |  | 999 | 200 |
| EJ321410 |  | CA14 Flare Package - JB Location drwgs |  | 25d | 2010-11-16 A | 2010-12-21 A | F4468 FF-20d, F4045 FF-20d | 100% |  |  |  |  |  | EJ321410 | EJ321410 | 86E | 14 | 200 | LEI | FL | E | J | EJ37 | 1410 | I | LND | C |  | 999 | 200 |

| ID | WBS | Activity | Type | Duration | Start | Finish | Predecessors | Complete | Resources | UDF_SAVE ACTID | UDF_SAVE ACT ID | Department | Constr. Area | Pro Unit/DocCode | PMT-Area | PMT-Phase | PMT-Respons. | WBS Phase | WBS Discipline | WBS Type of Work | WBS Objects | IMS | UPT | PMT-Schedule Org | TB26 Ressource Budget | Type of Work | Inquiry/Order No | PMT-Discipline | Zeigen/n. Zeigen |
| --- | --- | --- | --- | --- | --- | --- | --- | --- | --- | --- | --- | --- | --- | --- | --- | --- | --- | --- | --- | --- | --- | --- | --- | --- | --- | --- | --- | --- | --- |
|  | 1420 | **1420 Flare Knockout Drum Section - CA14** |  |  | 2008-04-01 | 2011-05-27 |  |  |  |  |  |  |  |  |  |  |  |  |  |  |  |  |  |  |  |  |  |  |  |
|  | C | **C Civil** |  |  | 2010-10-26 | 2011-04-21 |  |  |  |  |  |  |  |  |  |  |  |  |  |  |  |  |  |  |  |  |  |  |  |
| EC241130 |  | CA14 FlareKoDrum - Layout Drwg / Loads IFD |  | 34d | 2010-10-26 A | 2010-12-13 A | EB051130, EN251130 FF | 100% |  | EC241130 | EC241130 | 87A | 14 | 1420C01 | 200 | E | LND | E | C | EC24 | 1420 | de | LND |  |  |  |  |  |  |
| EC151130 |  | CA14 FlareKoDrum - Piling drwgs AFC |  | 55d | 2010-12-27 A | 2011-03-14 A | HEC15 FF, IMS-E-000130 FF, EC261130 SS | 100% |  | EC151130 | EC151130 | 87A | 14 | 1420C16 | 200 | E | AVR | E | C | EC15 | 1420 | PI | LND |  |  |  |  |  |  |
| EC261130 |  | CA14 FlareKoDrum - Civil Static Calc EqptFdtn |  | 55d | 2010-12-27 A | 2011-03-14 A | P3C0BD, EC241130 | 100% |  | EC261130 | EC261130 | 87A | 14 | 1420C14 | 200 | E | AVR | E | C | EC26 | 1420 | de | LND |  |  |  |  |  |  |
| EC281130 |  | CA14 FlareKoDrum - Formw/Reinforce drwgs AFC |  | 83d | 2010-12-27 A | 2011-04-21 A | EC151130 SS, EC261130 SS, EC45113015 FF | 100% |  | EC281130 | EC281130 | 87A | 14 | 1420C21 | 200 | E | AVR | E | C | EC28 | 1420 | cq | LND | 200 |  |  |  |  |  |
| EC45113005 |  | CA14 FlareKoDrum - Civil Layout drwgs AFC |  | 83d | 2010-12-27 A | 2011-04-21 A | HEC45C FF, AD2230, EC241130, EC261130 SS | 100% |  | EC45113005 | EC45113005 | 87A | 14 | 1420C13 | 200 | E | AVR | E | C | EC45 | 1420 | ar | LND |  |  |  |  |  |  |
| EC45113010 |  | CA14 FlareKoDrum - Civil Layout drwgs IFC | milestone | 0d | 2011-02-14 A | 2011-02-14 A | EC45113005 SF+35d | 100% |  | EC45113010 | EC45113010 | 87A | 14 |  | 200 | E | AVR | E | C | EC45 | 1420 | ar | LND |  |  |  |  |  |  |
| EC45113015 |  | CA14 FlareKoDrum - Review Civil Layout drwgs |  | 10d | 2011-02-15 A | 2011-02-28 A | EC45113010 | 100% |  | EC45113015 | EC45113015 | 87A | 14 |  | 200 | E | LND | E | C | EC45 | 1420 | ar | LND |  |  |  |  |  |  |
|  | N | **N Structural Steel** |  |  | 2010-09-21 | 2011-05-27 |  |  |  |  |  |  |  |  |  |  |  |  |  |  |  |  |  |  |  |  |  |  |  |
| EN151130 |  | CA14 FlareKoDrum - CAD Model/Concepts StrSteel |  | 25d | 2010-09-21 A | 2010-10-25 A | AD2230 FF, EN151410 SS | 100% | TKB-S [240 h] | EN151130 | EN151130 | 87B | 14 |  | 200 | E | LEI | E | N | EN15 | 1420 | de | LND | 200 | 240,00 | N02C | N02C | 055 | 0 |
| EN21113005 |  | CA14 FlareKoDrum SK1401 - GA-Drwgs + Fdtn Loads |  | 27d | 2010-10-28 A | 2010-12-06 A | EJ46113005, P3A02AB, AD2230 FS+80d, EN151130, ER161130, EE46113005 | 100% | TKB-S [160 h] | EN21113005 | EN21113005 | 87B | 14 |  | 200 |  | LEI | E | N | EN21 | 1420 | de | LND |  | 160,00 | N02C | N02C |  |  |
| EN24113005 |  | CA14 FlareKoDrum SK1401 - StaticCalc f.Fdtn Load |  | 25d | 2010-11-08 A | 2010-12-13 A | E3A02A40 SS+10d, EN21113005 FF+5d | 100% |  | EN24113005 | EN24113005 | 87B | 14 |  | 200 |  | LEI | E | N | EN24 | 1420 | de | LND |  |  | N02C | N02C |  |  |
| EN261130 |  | CA14 FlareKoDrum - Layout dwgs input for KM dwgs |  | 82d | 2010-11-15 A | 2011-03-11 A | EN24113010 FF, HEN26 FF, F4045 FF | 100% | TKB-S [560 h] | EN261130 | EN261130 | 87B | 14 |  | 200 |  | LEI | E | N | EN26 | 1420 | st | LND |  | 560,00 | N02C | N02C |  |  |
| EN21113010 |  | CA14 FlareKoDrum SK1401 - GA-Drwgs + Final Loads |  | 48d | 2010-12-21 A | 2011-02-28 A | EB051130, HEN21 FF, EN24113005, EN251130, EE46113008, EJ46113008 FS+10d, EN21113005 FS+10d | 100% | TKB-S [160 h] | EN21113010 | EN21113010 | 87B | 14 |  | 200 |  | LEI | E | N | EN21 | 1420 | de | LND |  | 160,00 | N02C | N02C |  |  |
| EN251130 |  | CA14 FlareKoDrum SK1401 - Loads for Civil | milestone | 0d | 2011-01-03 A | 2011-01-03 A | HEN25 FF, EN24113005 FF | 100% |  | EN251130 | EN251130 | 87B | 14 |  | 200 | E | LEI | E | N | EN25 | 1420 | de | LND | 200 |  | N02C | N02C | 055 | 0 |
| EN671130 |  | CA14 FlareKoDrum - Grating Cut-Out drwgs |  | 56d | 2011-01-21 A | 2011-04-08 A | ER421130 FF, F4468 FF+10d, EN261130 FF+20d | 100% | TKB-S [240 h] | EN671130 | EN671130 | 87B | 14 |  | 200 | C | LEI | E | N | EN67 | 1420 | de | LND | 200 | 240,00 | N02C | N02C |  |  |
| EN24113010 |  | CA14 FlareKoDrum SK1401 - Final Static Calc |  | 20d | 2011-02-14 A | 2011-03-11 A | EN21113010 | 100% |  | EN24113010 | EN24113010 | 87B | 14 |  | 200 |  | LEI | E | N | EN24 | 1420 | de | LND |  |  | N02C | N02C |  |  |
| EN27113005 |  | CA14 FlareKoDrum SK1401 - KM drwgs |  | 20d | 2011-03-14 A | 2011-04-08 A | EN261130, EN24113005 | 100% | KM Drwgs preparation by Cheljabinsk [21 t] | EN27113005 | EN27113005 | 87B | 14 |  | 200 |  | Chel | E | N | EN27 | 1420 | de | LND |  | 0,00 | N02C | N02C |  |  |
| EN681130 |  | CA14 FlareKoDrum - Grating Fabrication drwgs |  | 20d | 2011-03-28 A | 2011-04-22 A | EN671130 FF+10d, HEN68 FF | 100% |  | EN681130 | EN681130 | 87B | 14 |  | 200 | C | SC | E | N | EN68 | 1420 | de | LND | 200 |  | N02C | N02C |  |  |
| EN27113010 |  | CA14 FlareKoDrum SK1401- Check KM drwgs |  | 10d | 2011-04-11 A | 2011-04-22 A | EN27113005 | 100% |  | EN27113010 | EN27113010 | 87B | 14 |  | 200 |  | LEI | E | N | EN27 | 1420 | de | LND |  |  | N02C | N02C |  |  |
| EN641130 |  | CA14 FlareKoDrum SK1401 - Check Grating Cut-Out drwgs |  | 15d | 2011-04-11 A | 2011-04-29 A | EN671130 | 100% |  | EN641130 | EN641130 | 87B | 14 |  | 200 | C | LEI | E | N | EN67 | 1420 | de | LND | 200 |  | N02C | N02C |  |  |
| EN281130 |  | CA14 FlareKoDrum SK1401 - Shop dwgs(KMD) by Vend |  | 25d | 2011-04-25 A | 2011-05-27 A | EN27113010, HEN28 FF | 100% |  | EN281130 | EN281130 | 87B | 14 |  | 200 |  | Chel | E | N | EN28 | 1420 | de | LND |  |  | N02C | N02C |  |  |
|  | B | **B Mechanical - Stationary Equipment** |  |  | 2008-11-26 | 2008-11-26 |  |  |  |  |  |  |  |  |  |  |  |  |  |  |  |  |  |  |  |  |  |  |  |
| EB051130 |  | CA14 FlareKoDrum - Final Loads for Struc Steel | milestone | 0d | 2008-11-26 A | 2008-11-26 A | E3A02A20 SF | 100% |  | EB051130 | EB051130 | 869 | 14 |  | 200 |  | LND | E | B | EB05 | 1420 | 3 | LND |  |  |  |  |  |  |

Notes:
- EC45113005: P3 Activity Log Info: incl. PMT approval
- EC45113010: P3 Activity Log Info: incl. PMT approval
- EC45113015: P3 Activity Log Info: incl. PMT approval

| ID | WBS | Activity | Type | Duration | Start | Finish | Predecessors | Complete | Constraint | Resources | Cost | Actual cost | UDF_SAVE ACTID | UDF_SAVE ACT ID | Department | Constr. Area | PMT-Area | PMT-Respons. | WBS Phase | WBS Discipline | WBS Type of Work | WBS Objects | IMS | UPT | PMT-Phase | Pro Unit/DocCode | PMT-Schedule Org | Type of Work | Inquiry/Order No | PMT-Discipline | PMT-Doc. Type | Zeigen/n. Zeigen | TB26 Ressource Budget |
| --- | --- | --- | --- | --- | --- | --- | --- | --- | --- | --- | --- | --- | --- | --- | --- | --- | --- | --- | --- | --- | --- | --- | --- | --- | --- | --- | --- | --- | --- | --- | --- | --- | --- |
|  | R | **R Piping** |  |  | 2008-04-01 | 2011-05-05 |  |  |  |  |  |  |  |  |  |  |  |  |  |  |  |  |  |  |  |  |  |  |  |  |  |  |  |
| ER151130 |  | CA14 FlareKoDrum - Conceptual Piping |  | 169d | 2008-04-01 A | 2008-11-28 A | F2760 | 100% |  |  |  |  | ER151130 | ER151130 | 876 | 14 | 200 | LND | E | R | ER15 | 1420 | PL | LND |  |  |  |  |  |  |  |  |  |
| ER301130 |  | CA14 FlareKoDrum - CAD Model Piping / Eqpt |  | 648d | 2008-07-01 A | 2011-01-27 A | ER391130 FF+5d, ER151130 SS | 100% |  |  |  |  | ER301130 | ER301130 | 876 | 14 | 200 | LNI | E | R | ER30 | 1420 | PL | LND |  |  |  |  |  |  |  |  |  |
| ER161130 |  | CA14 FlareKoDrum - prelim Loads for SteelStruc |  | 20d | 2009-01-05 A | 2009-01-30 A | ER151130 FF | 100% |  |  |  |  | ER161130 | ER161130 | 876 | 14 | 200 | LND | E | R | ER16 | 1420 | PL | LND |  |  |  |  |  |  |  |  |  |
| ER421130 |  | CA14 FlareKoDrum - Stress Calculation |  | 71d | 2010-12-30 A | 2011-04-08 A | ER361130 FF | 100% | as late as possible |  |  |  | ER421130 | ER421130 | 872 | 14 | 200 | LND | E | R | ER42 | 1420 | PL | LND |  |  |  |  |  |  |  |  |  |
| ER451130 |  | CA14 FlareKoDrum - Piping Isometrics |  | 90d | 2010-12-30 A | 2011-05-05 A | ER301130 FF+10d, ER421130 FF, ER391130 FF | 100% | as late as possible |  |  |  | ER451130 | ER451130 | 876 | 14 | 200 | LEI | E | R | ER45 | 1420 | 5 | LND |  |  |  |  |  |  |  |  |  |
| ER191130 |  | CA14 FlareKoDrum - Final Loads for SteelStruc | milestone | 0d | 2011-01-03 A | 2011-01-03 A | ER161130 FF, EN21113010 SF-5d | 100% |  |  |  |  | ER191130 | ER191130 | 876 | 14 | 200 | LNI | E | R | ER19 | 1420 | PL | LND |  |  |  |  |  |  |  |  |  |
| ER491130 |  | CA14 FlareKoDrum - Design Check / Rel.Isos&BOM |  | 79d | 2011-01-17 A | 2011-05-05 A | ER451130 FF | 100% |  |  |  |  | ER491130 | ER491130 | 876 | 14 | 200 | LEI | E | R | ER49 | 1420 | 5 | LND |  |  |  |  |  |  |  |  |  |
| ER361130 |  | CA14 FlareKoDrum - CAD Model Review 60% |  | 3d | 2011-01-18 A | 2011-01-20 A | ER361410 FF, F4045 FF | 100% |  |  |  |  | ER361130 | ER361130 | 876 | 14 | 200 | LND | E | R | ER36 | 1420 | 2 | LND |  |  |  |  |  |  |  |  |  |
| ER391130 |  | CA14 FlareKoDrum - CAD Model Review 90% |  | 3d | 2011-01-18 A | 2011-01-20 A | F4468 FF | 100% |  |  |  |  | ER391130 | ER391130 | 876 | 14 | 200 | LND | E | R | ER39 | 1420 | 3 | LND |  |  |  |  |  |  |  |  |  |
|  | E | **E Electrical** |  |  | 2008-10-06 | 2011-01-18 |  |  |  |  |  |  |  |  |  |  |  |  |  |  |  |  |  |  |  |  |  |  |  |  |  |  |  |
| EE46113005 |  | CA14 FlareKoDrum - prelimLoads f.Struc Steel |  | 15d | 2008-10-06 A | 2008-10-24 A | F3060 FF | 100% |  |  |  |  | EE46113005 | EE46113005 | 874 | 14 |  | LND | E | E | EE11 | 1420 | E | LND | E |  |  |  |  |  |  |  |  |
| EE901130 |  | CA14 FlareKoDrum - Earthing Details |  | 30d | 2009-06-22 A | 2009-07-31 A | EE901201, HEE90 FF | 100% |  |  |  |  | EE901130 | EE901130 | 874 | 14 |  | LND | E | E | EE90 | 1420 | E | LND | E |  |  |  |  |  |  |  |  |
| EE761130 |  | CA14 FlareKoDrum - Layout Plan Light.&Sockets 1st Issue |  | 249d | 2010-01-26 A | 2011-01-18 A | EE000180 FS+10d | 100% |  |  |  |  | EE761130 | EE761130 | 874 | 14 |  | LEI | E | E | EE76 | 1420 | E | LND | E |  |  |  |  |  |  |  |  |
| EE46113008 |  | CA14 FlareKoDrum - Final Loads f.Struc Steel |  | 39d | 2010-10-26 A | 2010-12-20 A | EE46141005 | 100% |  |  |  |  | EE46113008 | EE46113008 | 874 | 14 |  | LEI | E | E | EE12 | 1420 | E | LND | E |  |  |  |  |  |  |  |  |
|  | J | **J Instrumentation** |  |  | 2008-10-06 | 2011-02-21 |  |  |  |  |  |  |  |  |  |  |  |  |  |  |  |  |  |  |  |  |  |  |  |  |  |  |  |
| EJ46113005 |  | CA14 FlareKoDrum - prelim Loads f.Struc Steel |  | 15d | 2008-10-06 A | 2008-10-24 A | F3060 FF | 100% |  |  |  |  | EJ46113005 | EJ46113005 | 86E | 14 |  | LND | E | J | EJ11 | 1420 | I | LND | E | 999 |  |  |  |  |  |  |  |
| EJ801130 |  | CA14 FlareKoDrum - Loop Diagrams |  | 70d | 2010-08-20 A | 2010-11-26 A | EJ800010, A1EJ0040 SF | 100% |  |  |  |  | EJ801130 | EJ801130 | 86E | 14 |  | LEI | E | J | EJ80 | 1420 | I | LND | E | 999 |  |  |  |  |  |  |  |
| EJ361130 |  | CA14 FlareKoDrum - Hook-Up drwgs |  | 84d | 2010-10-22 A | 2011-02-21 A | F4045 FF+10d, EJ360000 FF, A1EJ0080 | 100% |  |  |  |  | EJ361130 | EJ361130 | 86E | 14 | 200 | LEI | E | J | EJ36 | 1420 | I | LND | C | 999 | 200 |  |  |  |  |  |  |
| EJ46113008 |  | CA14 FlareKoDrum - Final Loads f.Struc Steel |  | 29d | 2010-10-26 A | 2010-12-06 A | EJ46113005 | 100% |  |  |  |  | EJ46113008 | EJ46113008 | 86E | 14 |  | LEI | E | J | EJ12 | 1420 | I | LND | E | 999 |  |  |  |  |  |  |  |
| EJ321130 |  | CA14 FlareKoDrum - JB Location drwgs |  | 25d | 2010-11-16 A | 2010-12-21 A | F4468 FF-20d, F4045 FF-20d | 100% |  |  |  |  | EJ321130 | EJ321130 | 86E | 14 | 200 | LEI | E | J | EJ37 | 1420 | I | LND | C | 999 | 200 |  |  |  |  |  |  |
|  | 15 | **15 CA15 - Instrument Air Buffer Vessel** |  |  | 2008-04-01 | 2011-04-11 |  |  |  |  |  |  |  |  |  |  |  |  |  |  |  |  |  |  |  |  |  |  |  |  |  |  |  |
|  | LUZ2 | **LUZ2 General ( )** |  |  | 2009-02-09 | 2011-01-07 |  |  |  |  |  |  |  |  |  |  |  |  |  |  |  |  |  |  |  |  |  |  |  |  |  |  |  |
|  | M | **M Mechanical - Rotating Equipment** |  |  | 2009-02-09 | 2011-01-07 |  |  |  |  |  |  |  |  |  |  |  |  |  |  |  |  |  |  |  |  |  |  |  |  |  |  |  |
| E3M1410 |  | M14 Submers. Pumps - Inquiry Spec. |  | 13d | 2009-02-09 A | 2009-02-25 A | F1670 SS+90d | 100% |  |  |  |  | E3M1410 | E3M1410 | 867 | 15 | 200 | LND | E | M | EM93 | LUZ2 | 3 | LND | E |  | 200 | M14 | 2PA6900 | 055 | DEV | 0 |  |
| E3M1420 |  | M14 Submers. Pumps - Techn. Eval./PO Spec |  | 171d | 2010-01-29 A | 2010-09-30 A | P3M14B FS+225d, HEB20 FF | 100% |  | TAM [800 h] |  |  | E3M1420 | E3M1420 | 867 | 15 | 200 | LND | E | M | EM94 | LUZ2 | 2 | LND | E |  | 200 | M14 | 2PA6900 | 055 |  | 0 | 800,00 |
| E3M1430 |  | M14 Submers. Pumps -Techn. Eval./Bid Tab F | milestone | 0d | 2010-09-20 A | 2010-09-20 A | E3M1420 FF-10d | 100% |  |  |  |  | E3M1430 | E3M1430 | 867 | 15 | 200 | LND | E | M | EM94 | LUZ2 | 2 | LND | E |  | 200 | M14 | 2PA6900 | 055 |  | 0 |  |
| E3M1440 |  | M14 Submers. Pumps - 1st Review dwgs |  | 10d | 2010-11-05 A | 2010-11-19 A | P3M14L SS+35d, HEB50 FF | 100% |  | TAM [320 h] |  |  | E3M1440 | E3M1440 | 867 | 15 | 200 | LND | E | M | EM25 | LUZ2 | 3 | LND | E |  | 200 | M14 | 2PA6900 | 055 |  | 0 | 320,00 |
| E3M1450 |  | M14 Submers. Pumps - Vendor dwgs approved | milestone | 0d | 2010-11-19 A | 2010-11-19 A | E3M1440 FF | 100% |  |  | 9,800 | 9,800 | E3M1450 | E3M1450 | 867 | 15 | 200 | LND | E | M | EM25 | LUZ2 | 3 | LND | E |  | 200 | M14 | 2PA6900 | 055 | DFA | 0 |  |
| E3M1460 |  | M14 Submers. Pumps - 2nd Review dwgs |  | 19d | 2010-12-10 A | 2011-01-07 A | E3B100 FF, P3M14L SS+70d | 100% |  | TAM [400 h] |  |  | E3M1460 | E3M1460 | 867 | 15 | 200 | LND | E | M | EM25 | LUZ2 | 3 | LND | E |  | 200 | M14 | 2PA6900 | 055 |  | 0 | 400,00 |

Notes:
- E3M1450: Expenses: 900A 9800

| ID | WBS | Activity | Type | Duration | Start | Finish | Predecessors | Complete | Resources | TB26 Ressource Budget | UDF_SAVE ACTID | UDF_SAVE ACT ID | Department | Constr. Area | Pro Unit/DocCode | Inquiry/Order No | PMT-Area | PMT-Phase | PMT-Respons. | Zeigen/n. Zeigen | WBS Phase | WBS Discipline | WBS Type of Work | WBS Objects | IMS | UPT | PMT-Schedule Org |
| --- | --- | --- | --- | --- | --- | --- | --- | --- | --- | --- | --- | --- | --- | --- | --- | --- | --- | --- | --- | --- | --- | --- | --- | --- | --- | --- | --- |
|  | 1500 | **1500 Generals - CA15** |  |  | 2010-04-19 | 2011-04-11 |  |  |  |  |  |  |  |  |  |  |  |  |  |  |  |  |  |  |  |  |  |
|  | C | **C Civil** |  |  | 2010-04-19 | 2011-04-11 |  |  |  |  |  |  |  |  |  |  |  |  |  |  |  |  |  |  |  |  |  |
| EC071505 |  | CA15 General - Issue of working drwgs (AFC) by RDI |  | 251d | 2010-04-19 A | 2011-04-11 A | EC601500 FF, EC151510 SS | 100% | TKB-B [1040 h] | 1040,00 | EC071505 | EC071505 | 87A | 15 | 1010C13 | 999 | 200 | E | IPR | FL | E | C | EC07 | 1500 | cq | LND |  |
| EC441500 |  | CA15 General - General Drwgs & Documents |  | 74d | 2010-05-07 A | 2010-08-20 A |  | 100% |  |  | EC441500 | EC441500 | 87A | 15 | 1500C11 |  | 200 | E | IPR |  | E | C | EC00 | 1500 | de | LND |  |
| EC071500 |  | CA15 General - Check & Release of working drwgs (AFC) |  | 124d | 2010-06-21 A | 2010-12-10 A | EC151510 SS+35d, EC601500 FF+5d | 100% | TKB-B [144 h] | 144,00 | EC071500 | EC071500 | 87A | 15 |  | 999 | 200 | E | LND | FL | E | C | EC07 | 1500 | cq | LND |  |
| EC601500 |  | CA15 General - Paving drwgs AFC |  | 135d | 2010-09-30 A | 2011-04-11 A | EC441500 FF+25d, EC301510 SS+20d | 100% |  |  | EC601500 | EC601500 | 87A | 15 | 9615C96 |  | 200 | E | IPR |  | E | C | EC60 | 1500 | de | LND | 200 |
|  | 1510 | **1510 Air Buffer Vessel Section - CA15** |  |  | 2008-04-01 | 2011-02-28 |  |  |  |  |  |  |  |  |  |  |  |  |  |  |  |  |  |  |  |  |  |
|  | C | **C Civil** |  |  | 2010-03-30 | 2010-10-08 |  |  |  |  |  |  |  |  |  |  |  |  |  |  |  |  |  |  |  |  |  |
| EC241510 |  | CA15 Air Buffer - Layout Drwg / Loads IFD |  | 27d | 2010-03-30 A | 2010-05-07 A | ER161510 FF, EB051510 | 100% |  |  | EC241510 | EC241510 | 87A | 15 | 1511C01 |  | 200 | E | LND |  | E | C | EC24 | 1510 | de | LND | 200 |
| EC151510 |  | CA15 Air Buffer - Piling drwgs AFC |  | 46d | 2010-04-19 A | 2010-06-23 A | EC261510 SS | 100% |  |  | EC151510 | EC151510 | 87A | 15 | 1511C16 |  | 200 |  | IPR |  | E | C | EC15 | 1510 | PI | LND |  |
| EC261510 |  | CA15 Air Buffer - Civil Static Calc EqptFdtn |  | 123d | 2010-04-19 A | 2010-10-08 A | EC241510 SS+12d, P3C0BD FS+10d | 100% |  |  | EC261510 | EC261510 | 87A | 15 | 1511C14 |  | 200 | E | IPR |  | E | C | EC26 | 1510 | de | LND | 200 |
| EC281510 |  | CA15 Air Buffer - Formw/Reinforce drwgs AFC |  | 103d | 2010-04-19 A | 2010-09-10 A | EC151510 SS+10d, EC261510 SS+10d | 100% |  |  | EC281510 | EC281510 | 87A | 15 | 1511C21 |  | 200 | E | IPR |  | E | C | EC28 | 1510 | cq | LND | 200 |
|  | B | **B Mechanical - Stationary Equipment** |  |  | 2008-11-26 | 2008-11-26 |  |  |  |  |  |  |  |  |  |  |  |  |  |  |  |  |  |  |  |  |  |
| EB051510 |  | CA15 Air Buffer - Final Loads for Struc Steel | milestone | 0d | 2008-11-26 A | 2008-11-26 A | E3A02A20 SF | 100% |  |  | EB051510 | EB051510 | 869 | 15 |  |  | 200 |  | LND |  | E | B | EB05 | 1510 | 3 | LND |  |
|  | R | **R Piping** |  |  | 2008-04-01 | 2011-02-28 |  |  |  |  |  |  |  |  |  |  |  |  |  |  |  |  |  |  |  |  |  |
| ER151510 |  | CA15 Air Buffer - Conceptual Piping |  | 169d | 2008-04-01 A | 2008-11-28 A | F2760 | 100% |  |  | ER151510 | ER151510 | 876 | 15 |  |  | 200 |  | LND |  | E | R | ER15 | 1510 | PL | LND |  |
| ER301510 |  | CA15 Air Buffer - CAD Model Piping / Eqpt |  | 517d | 2008-07-01 A | 2010-07-23 A | ER391510 FF+10d, ER161510 FF, ER151510 SS | 100% |  |  | ER301510 | ER301510 | 876 | 15 |  |  | 200 |  | LNI |  | E | R | ER30 | 1510 | PL | LND |  |
| ER161510 |  | CA15 Air Buffer - prel Loads for Steel Struc |  | 20d | 2009-01-05 A | 2009-01-30 A | ER151510 FF | 100% |  |  | ER161510 | ER161510 | 876 | 15 |  |  | 200 |  | LND |  | E | R | ER16 | 1510 | PL | LND |  |
| ER421510 |  | CA15 Air Buffer - Stress Calculation |  | 98d | 2009-11-16 A | 2010-04-09 A | ER361510 | 100% |  |  | ER421510 | ER421510 | 872 | 15 |  |  | 200 |  | LND |  | E | R | ER42 | 1510 | PL | LND |  |
| ER361510 |  | CA15 Air Buffer - CAD Model Review 60% |  | 15d | 2010-03-01 A | 2010-03-19 A | F4040 FF | 100% |  |  | ER361510 | ER361510 | 876 | 15 |  |  | 200 |  | LND |  | E | R | ER36 | 1510 | 2 | LND |  |
| ER391510 |  | CA15 Air Buffer - CAD Model Review 90% |  | 10d | 2010-06-28 A | 2010-07-09 A | F4460 FF | 100% |  |  | ER391510 | ER391510 | 876 | 15 |  |  | 200 |  | LND |  | E | R | ER39 | 1510 | 3 | LND |  |
| ER451510 |  | CA15 Air Buffer - Piping Isometrics |  | 51d | 2010-09-09 A | 2010-11-19 A | ER391510 FS+35d, ER301510 FF+20d, ER421510 | 100% |  |  | ER451510 | ER451510 | 876 | 15 |  |  | 200 |  | LEI |  | E | R | ER45 | 1510 | 5 | LND |  |
| ER441510 |  | CA15 General - Piping Isometrics (UG) |  | 20d | 2010-10-11 A | 2010-11-05 A | ER440000 FF, EC301510 SS+10d, HER44 FF | 100% |  |  | ER441510 | ER441510 | 876 | 15 |  |  | 200 | E | LND |  | E | R | ER44 | 1510 | 4 | LND | 200 |
| ER491510 |  | CA15 Air Buffer - Design Check/ Rel.Isos&BOM |  | 89d | 2010-10-22 A | 2011-02-28 A | ER451510 FF | 100% |  |  | ER491510 | ER491510 | 876 | 15 |  |  | 200 |  | LEI |  | E | R | ER49 | 1510 | 5 | LND |  |

Notes:
- EC441500: P3 Activity Log Info: incl. PMT approval

| ID | WBS | Activity | Type | Duration | Start | Finish | Predecessors | Complete | Planned start | Planned finish | Resources | UDF_SAVE ACTID | UDF_SAVE ACT ID | Department | Constr. Area | PMT-Phase | PMT-Respons. | WBS Phase | WBS Discipline | WBS Type of Work | WBS Objects | IMS | UPT | Pro Unit/DocCode | PMT-Area | PMT-Schedule Org | Type of Work | Inquiry/Order No | PMT-Discipline | PMT-Doc. Type | Zeigen/n. Zeigen | TB26 Ressource Budget |
| --- | --- | --- | --- | --- | --- | --- | --- | --- | --- | --- | --- | --- | --- | --- | --- | --- | --- | --- | --- | --- | --- | --- | --- | --- | --- | --- | --- | --- | --- | --- | --- | --- |
|  | E | **E Electrical** |  |  | 2009-04-06 | 2011-01-18 |  |  |  |  |  |  |  |  |  |  |  |  |  |  |  |  |  |  |  |  |  |  |  |  |  |  |
| EE901510 |  | CA15 Air Buffer - Earthing Details |  | 30d | 2009-04-06 A | 2009-05-20 A | EE901710 SS | 100% |  |  |  | EE901510 | EE901510 | 874 | 15 | E | LND | E | E | EE90 | 1510 | E | LND |  |  |  |  |  |  |  |  |  |
| EE561920 |  | CA15 Air Buffer - Cable Pulling Details |  | 259d | 2009-12-10 A | 2010-12-20 A | EE46161010 FF, EE500130 | 100% |  |  |  | EE561920 | EE561920 | 874 | 15 | E | LEI | E | E | EE56 | 1510 | E | LND |  |  |  |  |  |  |  |  |  |
| EE761510 |  | CA15 Air Buffer - Layout Plan Light.& Sockets 1st Issue |  | 249d | 2010-01-26 A | 2011-01-18 A | EE000140 FF+10d, EE000180 FS+10d | 100% |  |  |  | EE761510 | EE761510 | 874 | 15 | E | LEI | E | E | EE76 | 1510 | E | LND |  |  |  |  |  |  |  |  |  |
|  | J | **J Instrumentation** |  |  | 2008-10-06 | 2010-11-26 |  |  |  |  |  |  |  |  |  |  |  |  |  |  |  |  |  |  |  |  |  |  |  |  |  |  |
| EJ46151005 |  | CA15 Air Buffer - prelim Loads for Struc Steel |  | 15d | 2008-10-06 A | 2008-10-24 A | F3060 FF | 100% |  |  |  | EJ46151005 | EJ46151005 | 86E | 15 | E | LND | E | J | EJ11 | 1510 | I | LND | 999 |  |  |  |  |  |  |  |  |
| EJ361510 |  | CA15 Air Buffer - Hook-Up drwgs 1st Issue |  | 99d | 2010-02-08 A | 2010-06-30 A | F4040 FF+55d, A1EJ0080 | 100% |  |  |  | EJ361510 | EJ361510 | 86E | 15 | C | LEI | E | J | EJ36 | 1510 | I | LND | 999 | 200 | 200 |  |  |  |  |  |  |
| EJ46192010 |  | CA15 Air Buffer - Instr Cable Tray Layout Plans 1st Issue |  | 160d | 2010-03-01 A | 2010-10-14 A | EE46161010 FF+10d, F4460, F4040 FF | 100% |  |  |  | EJ46192010 | EJ46192010 | 86E | 15 | E | LEI | E | J | EJ41 | 1510 | I | LND | 999 |  |  |  |  |  |  |  |  |
| EJ321510 |  | CA15 Air Buffer - JB Location drwgs |  | 93d | 2010-07-12 A | 2010-11-18 A | F4460 FF+25d, F4040 | 100% |  |  |  | EJ321510 | EJ321510 | 86E | 15 | C | LEI | E | J | EJ37 | 1510 | I | LND | 999 | 200 | 200 |  |  |  |  |  |  |
| EJ801510 |  | CA15 Air Buffer - Loop Diagrams |  | 70d | 2010-08-20 A | 2010-11-26 A | A1EJ0040 SF, EJ800010 | 100% |  |  |  | EJ801510 | EJ801510 | 86E | 15 | E | LEI | E | J | EJ80 | 1510 | I | LND | 999 |  |  |  |  |  |  |  |  |
|  | 1511 | **1511 Sanitary Lifting Station Section - CA15** |  |  | 2009-02-09 | 2010-11-26 |  |  |  |  |  |  |  |  |  |  |  |  |  |  |  |  |  |  |  |  |  |  |  |  |  |  |
|  | C | **C Civil** |  |  | 2010-06-21 | 2010-11-26 |  |  |  |  |  |  |  |  |  |  |  |  |  |  |  |  |  |  |  |  |  |  |  |  |  |  |
| EC241511 |  | CA15 SanitLiftStat - Layout Drwg / Loads IFD |  | 79d | 2010-06-21 A | 2010-10-07 A | E3M1420 FF | 100% |  |  |  | EC241511 | EC241511 | 87A | 15 | E | LND | E | C | EC24 | 1511 | de | LND | 1510C01 | 200 | 200 |  |  |  |  |  |  |
| EC45151115 |  | CA15 SanitLiftStat - Rev Civil Layout drwgs |  | 10d | 2010-10-01 A | 2010-10-14 A |  | 100% |  |  |  | EC45151115 | EC45151115 | 87A | 15 | E | LND | E | C | EC45 | 1511 | ar | LND |  | 200 |  |  |  |  |  |  |  |
| EC261511 |  | CA15 SanitLiftStat - Civil Static Calc EqptFdtn |  | 35d | 2010-10-08 A | 2010-11-26 A | P3C0BD FS+15d, EC241511 | 100% |  |  |  | EC261511 | EC261511 | 87A | 15 | E | IPR | E | C | EC26 | 1511 | de | LND | 1510C14 | 200 | 200 |  |  |  |  |  |  |
| EC45151105 |  | CA15 SanitLiftStat - Civil Layout drwgs AFC |  | 35d | 2010-10-08 A | 2010-11-26 A | EC261511 SS, P3C0BD FS+15d, EC241511, AD2230 | 100% |  |  |  | EC45151105 | EC45151105 | 87A | 15 | E | IPR | E | C | EC45 | 1511 | ar | LND | 1510C13 | 200 |  |  |  |  |  |  |  |
|  | E | **E Electrical** |  |  | 2009-02-09 | 2010-11-12 |  |  |  |  |  |  |  |  |  |  |  |  |  |  |  |  |  |  |  |  |  |  |  |  |  |  |
| E3E2210 |  | E22 Diesel Generator - Inquiry Spec. |  | 10d | 2009-02-09 A | 2009-02-20 A | AD1740 | 100% |  |  |  | E3E2210 | E3E2210 | 87D | 15 | E | LND | E | E | EE44 | 1511 | E | LND |  | 200 | 200 | E22 | 2EB5450 | 055 | DEV | 0 |  |
| E3E2220 |  | E22 Diesel Generator - Techn. Eval./PO Spec. |  | 40d | 2010-02-22 A | 2010-04-20 A | P3E22B FS+245d | 100% |  |  | TAE [160 h] | E3E2220 | E3E2220 | 87D | 15 | E | LND | E | E | EE44 | 1511 | E | LND |  | 200 | 200 | E22 | 2EB5450 | 055 |  | 0 | 160,00 |
| E3E2230 |  | E22 Diesel Generator - Techn. Eval./Bid Tab F | milestone | 0d | 2010-03-26 A | 2010-03-26 A | E3E2220 FF-9d | 100% |  |  |  | E3E2230 | E3E2230 | 87D | 15 | E | LND | E | E | EE44 | 1511 | E | LND |  | 200 | 200 | E22 | 2EB5450 | 055 |  | 0 |  |
| E3E2250 |  | E22 Diesel Generator - Vendor dwgs approved (HAZOP input, rev. PO, changed Generator capacity) |  | 111d | 2010-06-11 A | 2010-11-12 A | HEE50 FF, IMS-E-000200 FF, P3E22L SS+50d | 100% |  |  | TAE [160 h] | E3E2250 | E3E2250 | 87D | 15 | E | LND | E | E | EE44 | 1511 | P | LND |  | 200 | 200 | E22 | 2EB5450 | 400 |  | 0 | 160,00 |
|  | 16 | **16 CA16 - Substation / RIE's** |  |  | 2008-02-29 | 2011-04-11 |  |  |  |  |  |  |  |  |  |  |  |  |  |  |  |  |  |  |  |  |  |  |  |  |  |  |
|  | LUZ2 | **LUZ2 General ( )** |  |  | 2009-07-01 | 2011-01-20 |  |  |  |  |  |  |  |  |  |  |  |  |  |  |  |  |  |  |  |  |  |  |  |  |  |  |
|  | E | **E Electrical** |  |  | 2009-07-01 | 2010-11-04 |  |  |  |  |  |  |  |  |  |  |  |  |  |  |  |  |  |  |  |  |  |  |  |  |  |  |
| E03E0210 |  | E02 PowerTransformer - Inquiry Spec. |  | 16d | 2009-07-01 A | 2009-07-22 A | AD1780, F1940 SS, F1980 SS+90d | 100% |  |  |  | E03E0210 | E03E0210 | 87D | 16 | E | LND | E | E | EE20 | LUZ2 | INS | LND |  | 200 | 200 | E02 | 2EB5620 | 055 | DEV | 0 |  |
| E3E01A10 |  | E01A MV-SWG/MCC - Inquiry Spec. |  | 18d | 2009-07-01 A | 2009-07-24 A | F1980 SS+90d, F1940 SS, AD1780 | 100% |  |  |  | E3E01A10 | E3E01A10 | 87D | 16 | E | LND | E | E | EE20 | LUZ2 | de | LND |  | 200 | 200 | E01A | 2EB5640 | 055 | DEV | 0 |  |
| E3E01B10 |  | E01B LV-SWG/MCC/Softstarter/FQ - Inquiry Spec. |  | 18d | 2009-07-01 A | 2009-07-24 A | F1940 SS, F1980 SS+90d, AD1780 | 100% |  |  |  | E3E01B10 | E3E01B10 | 87D | 16 | E | LND | E | E | EE20 | LUZ2 | P | LND |  | 200 | 200 | E01B | 2EB5630 | 055 | DEV | 0 |  |
| E3E0710 |  | E07 UPS/DC-System - Inquiry Spec. |  | 16d | 2009-07-01 A | 2009-07-22 A | E3E01B10 SS, F1940, AD1780, F1980 | 100% |  |  |  | E3E0710 | E3E0710 | 87D | 16 | E | LND | E | E | EE24 | LUZ2 | E | LND |  | 200 | 200 | E07 | 2EB5610 | 055 | DEV | 0 |  |
| E3E0220 |  | E02 PowerTransformer - Techn. Eval./PO Spec |  | 53d | 2009-12-10 A | 2010-02-26 A | P3E02B FS+96d | 100% |  |  | TAE [320 h] | E3E0220 | E3E0220 | 87D | 16 | E | LND | E | E | EE20 | LUZ2 | P | LND |  | 200 | 200 | E02 | 2EB5620 | 055 |  | 0 | 320,00 |
| E3E01A20 |  | E01A MV-SWG/MCC - Techn. Eval./PO Spec |  | 51d | 2009-12-14 A | 2010-02-26 A | P3E01AB FS+96d | 100% |  |  | TAE [640 h] | E3E01A20 | E3E01A20 | 87D | 16 | E | LND | E | E | EE20 | LUZ2 | E | LND |  | 200 | 200 | E01A | 2EB5640 | 055 |  | 0 | 640,00 |
| E3E01B20 |  | E01B LV-SWG/MCC/Softstarter/FQ - Techn. Eval./PO Spec |  | 47d | 2009-12-18 A | 2010-02-26 A | P3E01BB FS+100d | 100% |  |  | TAE [2000 h] | E3E01B20 | E3E01B20 | 87D | 16 | E | LND | E | E | EE20 | LUZ2 | P | LND |  | 200 | 200 | E01B | 2EB5630 | 055 |  | 0 | 2000,00 |
| E3E01A30 |  | E01A MV-SWG/MCC - Techn. Eval./Bid Tab | milestone | 0d | 2010-02-11 A | 2010-02-11 A | E3E01A20 FF-7d | 100% |  |  |  | E3E01A30 | E3E01A30 | 87D | 16 | E | LND | E | E | EE20 | LUZ2 | E | LND |  | 200 | 200 | E01A | 2EB5640 | 055 |  | 0 |  |
| E3E01B30 |  | E01B LV-SWG/MCC/Softstarter/FQ - Techn. Eval./Bid Tab | milestone | 0d | 2010-02-11 A | 2010-02-11 A | E3E01B20 FF-7d | 100% |  |  |  | E3E01B30 | E3E01B30 | 87D | 16 | E | LND | E | E | EE20 | LUZ2 | P | LND |  | 200 | 200 | E01B | 2EB5630 | 055 |  | 0 |  |
| E3E0230 |  | E02 PowerTransformer - Techn. Eval./Bid Tab | milestone | 0d | 2010-02-11 A | 2010-02-11 A | E3E0220 FF-7d | 100% |  |  |  | E3E0230 | E3E0230 | 87D | 16 | E | LND | E | E | EE20 | LUZ2 | P | LND |  | 200 | 200 | E02 | 2EB5620 | 055 |  | 0 |  |
| E3E0720 |  | E07 UPS/DC-System - Techn. Eval./PO Spec |  | 50d | 2010-02-16 A | 2010-04-28 A | P3E07B FS+140d, E3E01A20 FF+25d | 100% |  |  | TAE [320 h] | E3E0720 | E3E0720 | 87D | 16 | E | LND | E | E | EE24 | LUZ2 | E | LND |  | 200 | 200 | E07 | 2EB5610 | 055 |  | 0 | 320,00 |
| E3E0250 |  | E02 PowerTransformer - Vendor dwgs approved |  | 59d | 2010-03-26 A | 2010-06-22 A | HEE50 FF, P3E02L SS+27d | 100% |  |  | TAE [320 h] | E3E0250 | E3E0250 | 87D | 16 | E | LND | E | E | EE20 | LUZ2 | P | LND |  | 200 | 200 | E02 | 2EB5620 | 400 |  | 0 | 320,00 |
| E3E01A50 |  | E01A MV-SWG/MCC - Vendor dwgs approved |  | 53d | 2010-03-29 A | 2010-06-15 A | HEE50 FF, P3E01AL SS+30d | 100% |  |  | TAE [640 h] | E3E01A50 | E3E01A50 | 87D | 16 | E | LND | E | E | EE20 | LUZ2 | P | LND |  | 200 | 200 | E01A | 2EB5640 | 400 |  | 0 | 640,00 |
| E3E01B50 |  | E01B LV-SWG/MCC/Softstarter/FQ - Vendor dwgs approved |  | 136d | 2010-03-29 A | 2010-10-08 A | IMS-E-000200 FF, HEE50 FF, P3E01BL SS+30d | 100% |  |  | TAE [2000 h] | E3E01B50 | E3E01B50 | 87D | 16 | E | LND | E | E | EE20 | LUZ2 | P | LND |  | 200 | 200 | E01B | 2EB5630 | 400 |  | 0 | 2000,00 |
| E3E0730 |  | E07 UPS/DC-System - Techn. Eval./Bid Tab | milestone | 0d | 2010-03-31 A | 2010-03-31 A | E3E0720 FF-6d | 100% |  |  |  | E3E0730 | E3E0730 | 87D | 16 | E | LND | E | E | EE24 | LUZ2 | E | LND |  | 200 | 200 | E07 | 2EB5610 | 055 |  | 0 |  |
| E3E0750 |  | E07 UPS/DC-System - Vendor dwgs approved |  | 88d | 2010-06-09 A | 2010-10-09 A | HEE50 FF, P3E07L SS+40d, P3E13L SS+40d | 100% | 2010-06-09 | 2010-10-08 | TAE [320 h] | E3E0750 | E3E0750 | 87D | 16 | E | LND | E | E | EE24 | LUZ2 | P | LND |  | 200 | 200 | E07 | 2EB5610 | 400 |  | 0 | 320,00 |
| E3E1630 |  | E16 El.Cable Tray Syst. - Techn. Eval./Bid Tab | milestone | 0d | 2010-07-07 A | 2010-07-07 A | E3E1620 FF-12d | 100% |  |  |  | E3E1630 | E3E1630 | 87D | 16 | E | LND | E | E | EE29 | LUZ2 | E | LND |  | 200 | 200 | E16 | E16 | 055 |  | 0 |  |
| E3E15B30 |  | E15B Elec. LV Power Cable - Techn. Eval./Bid Tab | milestone | 0d | 2010-11-04 A | 2010-11-04 A | E3E15B20 FF-10d | 100% |  |  |  | E3E15B30 | E3E15B30 | 87D | 16 | E | LND | E | E | EE30 | LUZ2 | E | LND |  | 200 | 200 | E15B | 2EB6200 | 055 |  | 0 |  |
| E3E15C30 |  | E15C Cable Glands - Techn. Eval./Bid Tab | milestone | 0d | 2010-11-04 A | 2010-11-04 A | E3E15C20 FF-6d | 100% |  |  |  | E3E15C30 | E3E15C30 | 87E | 16 | E | LND | E | E | EE37 | LUZ2 | E | LND |  | 200 | 200 | E15C | 2EB6210 | 055 |  | 0 |  |
| E3E15A30 |  | E15A Elec. MV Power Cable - Techn. Eval./Bid Tab | milestone | 0d | 2010-11-04 A | 2010-11-04 A | E3E15A20 FF-10d | 100% |  |  |  | E3E15A30 | E3E15A30 | 87D | 16 | E | LND | E | E | EE26 | LUZ2 | E | LND |  | 200 | 200 | E15A | 2EB6110 | 055 |  | 0 |  |

Notes:
- EC45151115: P3 Activity Log Info: incl. PMT approval
- EC45151105: P3 Activity Log Info: incl. PMT approval
- E3E2250: Expenses: 900A 0
- E3E0250: Expenses: 900A 0
- E3E01A50: Expenses: 900A 0
- E3E01B50: Expenses: 900A 0
- E3E0750: Expenses: 900A 0

| ID | WBS | Activity | Type | Duration | Start | Finish | Predecessors | Complete | Resources | UDF_SAVE ACTID | UDF_SAVE ACT ID | Department | Type of Work | Constr. Area | Pro Unit/DocCode | Inquiry/Order No | PMT-Area | PMT-Schedule Org | PMT-Discipline | PMT-Phase | PMT-Respons. | Zeigen/n. Zeigen | WBS Phase | WBS Discipline | WBS Type of Work | WBS Objects | IMS | UPT | TB26 Ressource Budget |
| --- | --- | --- | --- | --- | --- | --- | --- | --- | --- | --- | --- | --- | --- | --- | --- | --- | --- | --- | --- | --- | --- | --- | --- | --- | --- | --- | --- | --- | --- |
|  | J | **J Instrumentation** |  |  | 2010-01-25 | 2011-01-20 |  |  |  |  |  |  |  |  |  |  |  |  |  |  |  |  |  |  |  |  |  |  |  |
| E3J0635 |  | J06 DCS / SIS - KO Meeting w. Client/Yokogawa | milestone | 0d | 2010-01-25 A | 2010-01-25 A | P3J06B, P3J06D1 | 100% |  | E3J0635 | E3J0635 | 86C | J06 | 16 | 999 | 2JD9220 | 200 | 200 | 055 | E | LND | 0 | E | J | EJ24 | LUZ2 | I | LND |  |
| E3J0644 |  | J06 DCS / SIS - HW FREEZE I/O-list, Home run cable | milestone | 0d | 2010-04-26 A | 2010-04-26 A | P3J06D2 FF+15d | 100% |  | E3J0644 | E3J0644 | 86C | J06 | 16 | 999 | 2JD9220 | 200 | 200 | 055 | E | LND | 0 | E | J | EJ24 | LUZ2 | I | LND |  |
| E3J0640 |  | J06 DCS / SIS - FEED completion (English) | milestone | 0d | 2010-05-07 A | 2010-05-07 A | P3J06D1 FF+94d | 100% |  | E3J0640 | E3J0640 | 86C | J06 | 16 | 999 | 2JD9220 | 200 | 200 | 055 | E | LND | 0 | E | J | EJ24 | LUZ2 | I | LND |  |
| E3J0637 |  | J06 DCS / SIS - KO Meeting HW (Dresden) |  | 2d | 2010-05-19 A | 2010-05-20 A | P3J06D2 FS+30d | 100% |  | E3J0637 | E3J0637 | 86C | J06 | 16 | 999 | 2JD9220 | 200 | 200 | 055 | E | LND | 0 | E | J | EJ24 | LUZ2 | I | LND |  |
| E3J0646 |  | J06 DCS / SIS - HW FREEZE Main | milestone | 0d | 2010-05-25 A | 2010-05-25 A | E3J0644 FF+19d | 100% |  | E3J0646 | E3J0646 | 86C | J06 | 16 | 999 | 2JD9220 | 200 | 200 | 055 | E | LND | 0 | E | J | EJ24 | LUZ2 | I | LND |  |
| E3J06E20 |  | J06E Junction Boxes - Techn. Eval./PO Spec |  | 168d | 2010-05-27 A | 2011-01-20 A | E3J06E10 FS+10d | 100% | TAP [2080 h] | E3J06E20 | E3J06E20 | 86C | J06E | 16 | 999 | 2JD9620 | 200 | 200 | 055 | E | LND | 0 | E | J | EJ24 | LUZ2 | I | LND | 2080,00 |
| E3J0642 |  | J06 DCS / SIS - SW FREEZE (Linde) | milestone | 0d | 2010-06-04 A | 2010-06-04 A | E3J0640 FF+18d | 100% |  | E3J0642 | E3J0642 | 86C | J06 | 16 | 999 | 2JD9220 | 200 | 200 | 055 | E | LND | 0 | E | J | EJ24 | LUZ2 | I | LND |  |
| E3J06A20 |  | J06A Power Cabinets - Techn. Eval./PO Spec |  | 71d | 2010-06-24 A | 2010-09-30 A | P3J06AB FS+25d | 100% | TAP [1280 h] | E3J06A20 | E3J06A20 | 86C | J06A | 16 | 999 | 2JD9640 | 200 | 200 | 055 | E | LND | 0 | E | J | EJ24 | LUZ2 | I | LND | 1280,00 |
| E3J06B20 |  | J06B Interface/Special Dev. Cabinets (E+I) - Techn. Eval./PO Spec |  | 68d | 2010-06-29 A | 2010-09-30 A | P3J06BB FS+20d | 100% | TAP [2560 h] | E3J06B20 | E3J06B20 | 86C | J06B | 16 | 999 | 2JD9640 | 200 | 200 | 055 | E | LND | 0 | E | J | EJ24 | LUZ2 | I | LND | 2560,00 |
| E3J06A30 |  | J06A Power Cabinets -Techn.Eval./Bid Tab | milestone | 0d | 2010-09-13 A | 2010-09-13 A | E3J06A20 FF-7d | 100% |  | E3J06A30 | E3J06A30 | 86C | J06A | 16 | 999 | 2JD9640 | 200 | 200 | 055 | E | LND | 0 | E | J | EJ24 | LUZ2 | I | LND |  |
| E3J06B30 |  | J06B Interface/Special Dev. Cabinets (E+I) -Techn.Eval./Bid Tab | milestone | 0d | 2010-09-22 A | 2010-09-22 A | E3J06B20 FF-7d | 100% |  | E3J06B30 | E3J06B30 | 86C | J06B | 16 | 999 | 2JD9640 | 200 | 200 | 055 | E | LND | 0 | E | J | EJ24 | LUZ2 | I | LND |  |
| E3J06A50 |  | J06A Power Supply Cab. - Vendor dwgs appr. | milestone | 0d | 2010-12-01 A | 2010-12-01 A | P3J06AL SF+40d | 100% |  | E3J06A50 | E3J06A50 | 86C | J06A | 16 | 999 | 2JD9640 | 200 | 200 |  | E | LND | 0 | E | J | EJ25 | LUZ2 | I | LND |  |
| E3J06B50 |  | J06B Interface/Special Dev. Cabinets (E+I)- Vendor dwgs appr. | milestone | 0d | 2010-12-01 A | 2010-12-01 A | P3J06BL SF+40d | 100% |  | E3J06B50 | E3J06B50 | 86C | J06B | 16 | 999 | 2JD9640 | 200 | 200 |  | E | LND | 0 | E | J | EJ25 | LUZ2 | I | LND |  |
|  | S | **S Safety & Environment** |  |  | 2010-05-10 | 2010-09-24 |  |  |  |  |  |  |  |  |  |  |  |  |  |  |  |  |  |  |  |  |  |  |  |
| E3S0550 |  | S05 Gas Exting. Syst. - Detailed Layout Drwgs (1st issue 07Jul received) |  | 98d | 2010-05-10 A | 2010-09-24 A | EC45161005 SS+40d | 100% |  | E3S0550 | E3S0550 | 871 | S05 | 16 |  | 2SI1770 | 200 | 200 | 055 | E | AVR | 0 | E | S | ES24 | LUZ2 | 1 | LND |  |
|  | 1600 | **1600 Generals - CA16** |  |  | 2010-02-22 | 2011-04-11 |  |  |  |  |  |  |  |  |  |  |  |  |  |  |  |  |  |  |  |  |  |  |  |
|  | C | **C Civil** |  |  | 2010-02-22 | 2011-04-11 |  |  |  |  |  |  |  |  |  |  |  |  |  |  |  |  |  |  |  |  |  |  |  |
| EC071600 |  | CA16 Subst&RIE's - Check & Release of working drwgs (AFC) |  | 155d | 2010-02-22 A | 2010-09-30 A | EC45161005 FF+10d | 100% | TKB-B [5152 h] | EC071600 | EC071600 | 87A |  | 16 |  | 999 | 200 |  |  | E | LND | FL | E | C | EC07 | 1600 | cq | LND | 5152,00 |
| EC071605 |  | CA16 Subst&RIE's - Issue of working drwgs (AFC) by RDI |  | 141d | 2010-02-22 A | 2010-09-10 A | EC501610 FF, EC701610 FF, EC45161005 SS+25d | 100% | TKB-B [21040 h] | EC071605 | EC071605 | 87A |  | 16 | 1010C13 | 999 | 200 |  |  | E | AVR | FL | E | C | EC07 | 1600 | cq | LND | 21040,00 |
| EC601600 |  | CA16 Subst&RIE's - Paving drwgs AFC |  | 233d | 2010-05-14 A | 2011-04-11 A | EC44161005 FF, EC48161012 FF, EC301600 SS | 100% |  | EC601600 | EC601600 | 87A |  | 16 | 9616C96 |  | 200 | 200 |  | E | IPR |  | E | C | EC60 | 1600 | de | LND |  |
|  | 1610 | **1610 Substation / RIE's - CA16** |  |  | 2008-02-29 | 2010-11-24 |  |  |  |  |  |  |  |  |  |  |  |  |  |  |  |  |  |  |  |  |  |  |  |
|  | 0B | **0B General Activities** |  |  | 2008-08-12 | 2008-08-12 |  |  |  |  |  |  |  |  |  |  |  |  |  |  |  |  |  |  |  |  |  |  |  |
| E0201610 |  | CA16 Subst&RIE's - freeze construction concept | milestone | 0d | 2008-08-12 A | 2008-08-12 A | F3600 FF | 100% |  | E0201610 | E0201610 | 87A |  | 16 |  |  | 200 |  |  | E |  |  | E | 0B | E020 | 1610 | INS | LND |  |

Notes:
- E3J06E20: Scope: 11.01.11 B. RoЯberg new vendor / recommendation
- E3J06A50: Expenses: 900A 0
- E3J06B50: Expenses: 900A 0
- E3S0550: Expenses: 900A 0

| ID | WBS | Activity | Type | Duration | Start | Finish | Predecessors | Complete | UDF_SAVE ACTID | UDF_SAVE ACT ID | Department | Constr. Area | PMT-Area | PMT-Phase | PMT-Respons. | WBS Phase | WBS Discipline | WBS Type of Work | WBS Objects | IMS | UPT | Pro Unit/DocCode | PMT-Schedule Org | Type of Work | Inquiry/Order No | Zeigen/n. Zeigen |
| --- | --- | --- | --- | --- | --- | --- | --- | --- | --- | --- | --- | --- | --- | --- | --- | --- | --- | --- | --- | --- | --- | --- | --- | --- | --- | --- |
|  | C | **C Civil** |  |  | 2008-02-29 | 2010-08-31 |  |  |  |  |  |  |  |  |  |  |  |  |  |  |  |  |  |  |  |  |
| EC421610 |  | CA16 Subst&RIE's - Building Concept |  | 172d | 2008-02-29 A | 2008-11-04 A | F2760 | 100% | EC421610 | EC421610 | 87A | 16 | 200 | E | LND | E | C | EC42 | 1610 | cq | LND |  |  |  |  |  |
| EC441610 |  | CA16 Subst&RIE's - Building Layout drwgs / Loads IFD |  | 77d | 2008-09-29 A | 2009-01-23 A | EE46161005 FF, EC421610, E0201610, EJ46161005 FF, AD2230 FF | 100% | EC441610 | EC441610 | 87A | 16 | 200 | E | LND | E | C | EC44 | 1610 | de | LND | 1601C01 |  |  |  |  |
| EC45161005 |  | CA16 Subst&RIE's - Building Layout drwgs AFC |  | 153d | 2010-01-18 A | 2010-08-24 A | EC48100 FF, E3C110 FF, IMS-E-000170 FF, EC131610 SS, AD2230, P3C0CD, E3E01A50 FF, EC441610 | 100% | EC45161005 | EC45161005 | 87A | 16 | 200 | E | AVR | E | C | EC45 | 1610 | ar | LND | 1601C13 |  |  |  |  |
| EC131610 |  | CA16 Subst&RIE's - Fire Safety Survey Report (1st issue) |  | 114d | 2010-01-25 A | 2010-07-07 A | EC461610 SS | 100% | EC131610 | EC131610 | 87A | 16 | 200 |  | AVR | E | C | EC13 | 1610 | de | LND | 1601C15 |  |  |  |  |
| EC461610 |  | CA16 Subst&RIE's - Civil Static Calc Bldg |  | 106d | 2010-01-25 A | 2010-06-25 A | EC441610, P3C0CD FS+5d, EJ46161008 FF+10d | 100% | EC461610 | EC461610 | 87A | 16 | 200 | E | AVR | E | C | EC46 | 1610 | de | LND | 1601C14 |  |  |  |  |
| EC151610 |  | CA16 Subst&RIE's - Piling drwgs AFC |  | 30d | 2010-02-08 A | 2010-03-19 A | EC461610 SS+10d, EC131610 SS+10d | 100% | EC151610 | EC151610 | 87A | 16 | 200 | E | AVR | E | C | EC15 | 1610 | PI | LND | 1601C16 |  |  |  |  |
| EC44161005 |  | CA16 Subst&RIE's - General Drwgs & Documents |  | 72d | 2010-03-01 A | 2010-06-14 A | EC48161003 SS | 100% | EC44161005 | EC44161005 | 87A | 16 | 200 | E | AVR | E | C | EC44 | 1610 | de | LND | 1600C11 |  |  |  |  |
| EC48161003 |  | CA16 Subst&RIE's - Formw/Reinf drwgs Found. AFC |  | 46d | 2010-03-01 A | 2010-05-05 A | EC151610 FF+10d, EC461610 SS+25d | 100% | EC48161003 | EC48161003 | 87A | 16 | 200 | E | AVR | E | C | EC48 | 1610 | ar | LND | 1601C21 | 200 |  |  |  |
| EC48161004 |  | CA16 Subst&RIE's - Precast dwgs AFC |  | 52d | 2010-03-08 A | 2010-05-21 A | EC461610 SS+30d, EC151610 FF+10d, EC48161003 SS | 100% | EC48161004 | EC48161004 | 87A | 16 | 200 | E | AVR | E | C | EC48 | 1610 | PRE | LND | 1601C31 | 200 |  |  |  |
| EC48161006 |  | CA16 Subst&RIE's - Precast Formw/Reinf. dwgs +0,00m AFC - Columns |  | 58d | 2010-03-08 A | 2010-06-01 A | E3E01A50 SF, EC48161004 SS, E3E0250 SF | 100% | EC48161006 | EC48161006 | 87A | 16 | 200 | E | AVR | E | C | EC48 | 1610 | ar | LND | 1601C53 | 200 |  |  |  |
| EC48161007 |  | CA16 Subst&RIE's - Precast Formw/Reinf. dwgs +0,00m AFC - Remaining |  | 67d | 2010-03-08 A | 2010-06-14 A | E3E0250 SF, E3E01A50 SF, EC48161004 SS | 100% | EC48161007 | EC48161007 | 87A | 16 | 200 | E | AVR | E | C | EC48 | 1610 | ar | LND | 1601C53 | 200 |  |  |  |
| EC48161005 |  | CA16 Subst&RIE's - Formw/Reinf drwgs GF +0,00 AFC |  | 62d | 2010-03-15 A | 2010-06-14 A | EC461610 SS+30d, EC48161003 FF+10d | 100% | EC48161005 | EC48161005 | 87A | 16 | 200 | E | AVR | E | C | EC48 | 1610 | ar | LND | 1601C22 | 200 |  |  |  |
| EC48161008 |  | CA16 Subst&RIE's - Precast Formw/Reinf. dwgs +3,00m AFC |  | 58d | 2010-03-22 A | 2010-06-15 A | E3E0250 SF, EC48161007 FF, E3E01A50 FF, EC48161006 FF | 100% | EC48161008 | EC48161008 | 87A | 16 | 200 | E | AVR | E | C | EC48 | 1610 | ar | LND | 1601C54 | 200 |  |  |  |
| EC48161010 |  | CA16 Subst&RIE's - Formw/Reinf drwgs Struc +3,00m AFC |  | 86d | 2010-03-29 A | 2010-07-30 A | EC48161005 FF+10d, EC461610 SF+30d, EH241610 SF | 100% | EC48161010 | EC48161010 | 87A | 16 | 200 | E | AVR | E | C | EC48 | 1610 | ar | LND | 1601C23 | 200 |  |  |  |
| EC48161015 |  | CA16 Subst&RIE's - Precast Formw/Reinf. dwgs +9,20m AFC |  | 66d | 2010-04-12 A | 2010-07-14 A | EC48161008 FF | 100% | EC48161015 | EC48161015 | 87A | 16 | 200 | E | AVR | E | C | EC48 | 1610 | ar | LND | 1601C55 | 200 |  |  |  |
| EC701610 |  | CA16 Subst&RIE's - Girder/Cladding - Structural Steel drwgs (KM) |  | 100d | 2010-04-12 A | 2010-08-31 A | EC45161005 FF | 100% | EC701610 | EC701610 | 87A | 16 | 200 |  | AVR | E | C | EC70 | 1610 | de | LND | 1601N51 |  | N02B | N02B |  |
| EC45161010 |  | CA16 Subst&RIE's - Building Layout drwgs IFC | milestone | 0d | 2010-04-22 A | 2010-04-22 A | EC45161005 FF-14d | 100% | EC45161010 | EC45161010 | 87A | 16 | 200 | E | AVR | E | C | EC45 | 1610 | ar | LND |  |  |  |  |  |
| EC45161015 |  | CA16 Subst&RIE's - Review Building Layout drwgs |  | 10d | 2010-04-22 A | 2010-05-05 A | EC45161010 | 100% | EC45161015 | EC45161015 | 87A | 16 | 200 | E | LND | E | C | EC45 | 1610 | ar | LND |  |  |  |  |  |
| EC48161012 |  | CA16 Subst&RIE's - Formw/Reinf drwgs Roof +9,20m AFC |  | 85d | 2010-04-22 A | 2010-08-20 A | EC48161010 FF | 100% | EC48161012 | EC48161012 | 87A | 16 | 200 | E | AVR | E | C | EC48 | 1610 | ar | LND | 1601C24 | 200 |  |  |  |
| EC501610 |  | CA16 Subst&RIE's - Architec Det.drwgs Bldg AFC (1st part) |  | 72d | 2010-05-14 A | 2010-08-24 A | E3E01B20 SS+20d, E3E01A20 SS+20d, E3E0220 SS+20d, E3E0720 SS+20d | 100% | EC501610 | EC501610 | 87A | 16 | 200 | E | AVR | E | C | EC50 | 1610 | ar | LND | 1601C41 | 200 |  |  |  |
| EC521610 |  | CA16 Subst&RIE's - False Floor drwgs AFC |  | 72d | 2010-05-14 A | 2010-08-24 A | EC48161012 FF, E3E01A50 FF | 100% | EC521610 | EC521610 | 87A | 16 | 200 | E | AVR | E | C | EC52 | 1610 | ar | LND | 1601C42 | 200 |  |  |  |
|  | N | **N Structural Steel** |  |  | 2010-08-23 | 2010-11-24 |  |  |  |  |  |  |  |  |  |  |  |  |  |  |  |  |  |  |  |  |
| EN671610 |  | CA16 Subst&RIE's - Grating Cut-Out drwgs |  | 29d | 2010-08-23 A | 2010-09-30 A | EC701610 FF, F4460 FF+10d | 100% | EN671610 | EN671610 | 87B | 16 | 200 | C | AVR | E | N | EN67 | 1610 | de | LND |  | 200 | N02B | N02B | FL |
| EN27161010 |  | CA16 Subst&RIE's - Girder/Cladding - Check KM drwgs |  | 10d | 2010-08-24 A | 2010-09-06 A | EC701610 FF+4d | 100% | EN27161010 | EN27161010 | 87B | 16 | 200 |  | LND | E | N | EN27 | 1610 | de | LND |  |  | N02B | N02B | FL |
| EN281610 |  | CA16 Subst&RIE's - Girder/Cladding - Shop dwgs(KMD) by Vend |  | 56d | 2010-09-07 A | 2010-11-24 A | IMS-E-000180 FF, EN27161010, IMS-E-000120 FF | 100% | EN281610 | EN281610 | 87B | 16 | 200 |  | Chel | E | N | EN28 | 1610 | de | LND |  |  | N02B | N02B | FL |
| EN641610 |  | CA16 Subst&RIE's - Check Grating Cut-Out drwgs |  | 10d | 2010-10-01 A | 2010-10-14 A | EN671610 | 100% | EN641610 | EN641610 | 87B | 16 | 200 | C | LND | E | N | EN64 | 1610 | de | LND |  | 200 | N02B | N02B |  |
| EN681610 |  | CA16 Subst&RIE's - Grating Fabrication drwgs |  | 10d | 2010-10-01 A | 2010-10-14 A | EN671610, EN641610 FF | 100% | EN681610 | EN681610 | 87B | 16 | 200 | C | Chel | E | N | EN68 | 1610 | de | LND |  | 200 | N02B | N02B | FL |

Notes:
- EC421610: P3 Activity Log Info: fixed Layout
- EC441610: P3 Activity Log Info: incl. PMT approval
- EC45161005: P3 Activity Log Info: incl. PMT approval
- EC461610: P3 Activity Log Info: Organisierung von Res (D-lokal oder Indien)
- EC44161005: P3 Activity Log Info: incl. PMT approval
- EC45161010: P3 Activity Log Info: incl. PMT approval
- EC45161015: P3 Activity Log Info: incl. PMT approval

| ID | WBS | Activity | Type | Duration | Start | Finish | Predecessors | Complete | Resources | UDF_SAVE ACTID | UDF_SAVE ACT ID | Department | Constr. Area | PMT-Area | PMT-Schedule Org | PMT-Discipline | PMT-Phase | PMT-Respons. | WBS Phase | WBS Discipline | WBS Type of Work | WBS Objects | IMS | UPT | TB26 Ressource Budget | Pro Unit/DocCode | PMT-Stage | Zeigen/n. Zeigen | UDF_CONTRACT START DATE | UDF_CONTRACT FINISH DATE | UDF_CONTRACT ITEM |
| --- | --- | --- | --- | --- | --- | --- | --- | --- | --- | --- | --- | --- | --- | --- | --- | --- | --- | --- | --- | --- | --- | --- | --- | --- | --- | --- | --- | --- | --- | --- | --- |
|  | H | **H HVAC** |  |  | 2008-11-24 | 2010-09-07 |  |  |  |  |  |  |  |  |  |  |  |  |  |  |  |  |  |  |  |  |  |  |  |  |  |
| EH201610 |  | CA16 Subst&RIE's - HVAC&Plumbing / Feed/Basic |  | 165d | 2008-11-24 A | 2009-07-24 A | AD2230 FF+20d | 100% |  | EH201610 | EH201610 | 87C | 16 | 200 | 200 | 035 | E | LND | E | H | EH20 | 1610 | OTH | LND |  |  |  |  |  |  |  |
| EH30161005 |  | CA16 Subst&RIE's - HVAC Layouts Dwgs AFC |  | 158d | 2010-01-25 A | 2010-09-07 A | P3C0CD FS+5d, E3H0150 SS, EH201610 | 100% | TKB-H [800 h] | EH30161005 | EH30161005 | 87C | 16 | 200 | 200 | 035 | E | AVR | E | H | EH30 | 1610 | OTH | LND | 800,00 | 1601H23 |  |  |  |  |  |
| EH40161005 |  | CA16 Subst&RIE's - HVAC Calculations&Flow Diagrams |  | 152d | 2010-01-25 A | 2010-08-30 A | EH30161005 SS | 100% | TKB-H [640 h] | EH40161005 | EH40161005 | 87C | 16 | 200 | 200 | 035 | E | AVR | E | H | EH40 | 1610 | OTH | LND | 640,00 | 1601H22 |  |  |  |  |  |
| EH071610 |  | CA16 Subst&RIE's - Issue of Dwgs&Doc's by RDI | level of effort | 118d | 2010-03-22 A | 2010-09-07 A | EH30161005 SS+40d, EH30161005 FF, EH40161010 FF | 100% | TKB-H [7600 h] | EH071610 | EH071610 | 87C | 16 | 200 | 200 | 035 | E | AVR | E | H | EH30 | 1610 | OTH | LND | 7600,00 |  |  |  |  |  |  |
| EH30161015 |  | CA16 Subst&RIE's - Review HVAC Layout Dwgs |  | 81d | 2010-05-17 A | 2010-09-07 A | EH30161010 FF-5d | 100% | TKB-H [800 h] | EH30161015 | EH30161015 | 87C | 16 | 200 | 200 | 035 | E | LND | E | H | EH30 | 1610 | OTH | LND | 800,00 |  |  |  |  |  |  |
| EH30161010 |  | CA16 Subst&RIE's - HVAC Layouts Dwgs IFC | milestone | 0d | 2010-06-28 A | 2010-06-28 A | EH30161005 FF-12d | 100% |  | EH30161010 | EH30161010 | 87C | 16 | 200 | 200 | 035 | E | AVR | E | H | EH30 | 1610 | OTH | LND |  |  |  |  |  |  |  |
| EH40161010 |  | CA16 Subst&RIE's - HVAC Calc./Diagrams IFC | milestone | 0d | 2010-06-28 A | 2010-06-28 A | EH40161005 FF-12d | 100% |  | EH40161010 | EH40161010 | 87C | 16 | 200 | 200 | 035 | E | AVR | E | H | EH40 | 1610 | OTH | LND |  |  |  |  |  |  |  |
| EH241610 |  | CA16 Subst&RIE's - Wall & Floor opening details | milestone | 0d | 2010-08-27 A | 2010-08-27 A | EH051610, E3H0150 SS | 100% |  | EH241610 | EH241610 | 87C | 16 | 200 | 200 | 035 | E | AVR | E | H | EH24 | 1610 | OTH | LND |  | 1601H21 |  |  |  |  |  |
| EH051610 |  | CA16 Subst&RIE's - Final Loads f.Civil/Steel | milestone | 0d | 2010-08-27 A | 2010-08-27 A | E3H0150 SS, EH30161005 FF | 100% |  | EH051610 | EH051610 | 87C | 16 | 200 |  |  |  | AVR | E | H | EH12 | 1610 | OTH | LND |  |  |  |  |  |  |  |
|  | R | **R Piping** |  |  | 2010-10-04 | 2010-11-05 |  |  |  |  |  |  |  |  |  |  |  |  |  |  |  |  |  |  |  |  |  |  |  |  |  |
| ER441600 |  | CA16 Subst&RIE's - Piping Isometrics (UG) |  | 25d | 2010-10-04 A | 2010-11-05 A | EC301600 SS+10d, ER440000 FF | 100% |  | ER441600 | ER441600 | 876 | 16 | 200 | 200 |  | E | LND | E | R | ER44 | 1610 | 4 | LND |  |  |  |  |  |  |  |
|  | E | **E Electrical** |  |  | 2008-03-03 | 2010-10-20 |  |  |  |  |  |  |  |  |  |  |  |  |  |  |  |  |  |  |  |  |  |  |  |  |  |
| F1950 |  | CA16 Subst - Layout Bldg + outline drawing |  | 82d | 2008-03-03 A | 2008-06-30 A | F3600 | 100% |  | F1950 | F1950 | 874 | 16 | 200 | 200 | 065 | F | LND | E | E | EE19 | 1610 | 1 | LND |  |  | 3A | 1 |  |  |  |
| EE200040 |  | CA16 Subst - Layout Plan Switchgear Rooms |  | 366d | 2008-07-07 A | 2009-12-18 A | E3E01A20 FF, E3E01A50 FF, E3E0220 FF, E3E01B50 FF, E3E0250 FF, E3E01B20 FF | 100% |  | EE200040 | EE200040 | 874 | 16 |  |  |  | E | LND | E | E | EE19 | 1610 | E | LND |  |  |  |  |  |  |  |
| EE46161005 |  | CA16 Subst&RIE's - prelimLoads f.Civil /StrSteel |  | 10d | 2008-10-06 A | 2008-10-17 A | F3060 FF | 100% |  | EE46161005 | EE46161005 | 874 | 16 |  |  |  | E | LND | E | E | EE11 | 1610 | E | LND |  |  |  |  |  |  |  |
| EE901610 |  | CA16 Subst&RIE's - Earthing Details |  | 30d | 2009-02-23 A | 2009-04-03 A | EE903110 SS | 100% |  | EE901610 | EE901610 | 874 | 16 |  |  |  | E | LND | E | E | EE90 | 1610 | E | LND |  |  |  |  |  |  |  |
| EE46161010 |  | CA16 Subst - El. CableTray Layout Pl. 1st Issue |  | 206d | 2009-12-07 A | 2010-09-30 A | EE460000, F4040 FF+10d | 100% |  | EE46161010 | EE46161010 | 874 | 16 |  |  |  | E | LND | E | E | EE46 | 1610 | E | LND |  |  |  |  |  |  |  |
| EE561610 |  | CA16 Subst&RIE's - Cable Pulling Details |  | 217d | 2009-12-10 A | 2010-10-20 A | EE500130, EE46161010 FF | 100% |  | EE561610 | EE561610 | 874 | 16 |  |  |  | E | LEI | E | E | EE56 | 1610 | E | LND |  |  |  |  |  |  |  |
| EE761600 |  | CA16 Subst&RIE's - Layout Plan Light.& Sockets 1st Issue |  | 165d | 2010-01-26 A | 2010-09-17 A | EC501610 SF, EE000180 | 100% |  | EE761600 | EE761600 | 874 | 16 |  |  |  | E | AVR | E | E | EE76 | 1610 | E | LND |  |  |  |  |  |  |  |
| EE201610 |  | CA16 Subst - Layout Plan ElectrSubstation |  | 78d | 2010-02-22 A | 2010-06-15 A | F1950, E3E01A50 FF, EE200040 FF+10d | 100% | TAE [320 h] | EE201610 | EE201610 | 874 | 16 | 200 |  |  |  | LND | E | E | EE19 | 1610 | E | LND | 320,00 |  |  |  |  |  |  |
|  | J | **J Instrumentation** |  |  | 2008-10-06 | 2010-09-30 |  |  |  |  |  |  |  |  |  |  |  |  |  |  |  |  |  |  |  |  |  |  |  |  |  |
| EJ46161005 |  | CA16 Subst&RIE's - prelim Loads f.Civil/StrSteel |  | 10d | 2008-10-06 A | 2008-10-17 A | F3060 FF | 100% |  | EJ46161005 | EJ46161005 | 86E | 16 |  |  |  | E | LND | E | J | EJ11 | 1610 | I | LND |  | 999 |  |  |  |  |  |
| EJ461610 |  | CA16 Subst&RIE's - Instr Cable Tray Layout Pl. 1st Issue |  | 150d | 2010-03-01 A | 2010-09-30 A | F4460, EE46161010 FF, F4040 FF | 100% |  | EJ461610 | EJ461610 | 86E | 16 |  |  |  | E | LEI | E | J | EJ41 | 1610 | I | LND |  | 999 |  |  | 2011-03-10 | 2011-04-30 | E-15-01-10 |
| EJ46161008 |  | CA16 Subst&RIE's - Final Loads f.Civil/StrSteel |  | 15d | 2010-03-08 A | 2010-03-26 A | EJ46161005 | 100% |  | EJ46161008 | EJ46161008 | 86E | 16 |  |  |  | E | LEI | E | J | EJ12 | 1610 | I | LND |  | 999 |  |  |  |  |  |

Notes:
- F1950: P3 Activity Log Info: 15.10

| ID | WBS | Activity | Type | Duration | Start | Finish | Predecessors | Complete | Resources | Cost | Actual cost | UDF_SAVE ACTID | UDF_SAVE ACT ID | Department | Type of Work | Constr. Area | Inquiry/Order No | PMT-Area | PMT-Schedule Org | PMT-Discipline | PMT-Phase | PMT-Doc. Type | PMT-Respons. | Zeigen/n. Zeigen | WBS Phase | WBS Discipline | WBS Type of Work | WBS Objects | IMS | UPT | Pro Unit/DocCode | PMT-Stage | TB26 Ressource Budget |
| --- | --- | --- | --- | --- | --- | --- | --- | --- | --- | --- | --- | --- | --- | --- | --- | --- | --- | --- | --- | --- | --- | --- | --- | --- | --- | --- | --- | --- | --- | --- | --- | --- | --- |
|  | 17 | **17 CA17 - Extruder Pack / Additive Handling-Line1/2** |  |  | 2008-03-03 | 2011-05-04 |  |  |  |  |  |  |  |  |  |  |  |  |  |  |  |  |  |  |  |  |  |  |  |  |  |  |  |
|  | LUZ2 | **LUZ2 General ( )** |  |  | 2008-03-03 | 2011-01-14 |  |  |  |  |  |  |  |  |  |  |  |  |  |  |  |  |  |  |  |  |  |  |  |  |  |  |  |
|  | U | **U Package Units** |  |  | 2008-04-09 | 2010-12-10 |  |  |  |  |  |  |  |  |  |  |  |  |  |  |  |  |  |  |  |  |  |  |  |  |  |  |  |
| E3U2210 |  | PU22 Vacuum System - Inquiry Spec. |  | 15d | 2008-04-09 A | 2008-04-29 A | F1670 SS+34d | 100% |  |  |  | E3U2210 | E3U2210 | 869 | PU22 | 17 | 2DC9170 | 200 | 200 | 055 | E | DEV | LND | 0 | E | U | EU93 | LUZ2 | 3 | LND |  |  |  |
| E3U0220 |  | PU02 Add. Feed Syst. - Techn. Eval./PO Spec |  | 123d | 2008-05-05 A | 2008-10-24 A | F8060, P3U02C FF | 100% |  |  |  | E3U0220 | E3U0220 | 869 | PU02 | 17 | 2DC9820 | 200 | 200 | 400 | E |  | LND | C2 | E | U | EU24 | LUZ2 | 1 | LND | DC | 3A |  |
| E3U0230 |  | PU02 Add. Feed Syst. - Techn. Eval./Bid Tab Fin | milestone | 0d | 2008-07-12 A | 2008-07-12 A | F8140, E3U0220 FF-6d | 100% |  |  |  | E3U0230 | E3U0230 | 869 | PU02 | 17 | 2DC9820 | 200 | 200 | 055 | E |  | LND | C2 | E | U | EU24 | LUZ2 | 1 | LND |  |  |  |
| E3U2220 |  | PU22 Vacuum System - Techn. Eval./PO Spec |  | 174d | 2008-10-16 A | 2009-07-02 A | P3U22B FS+115d | 100% |  |  |  | E3U2220 | E3U2220 | 869 | PU22 | 17 | 2DC9170 | 200 | 200 | 055 | E |  | LND | 0 | E | U | EU94 | LUZ2 | 3 | LND |  |  |  |
| E3U0240 |  | PU02 Add. Feed Syst. - 1st Review Vendor Dwgs |  | 33d | 2009-01-07 A | 2009-02-20 A | P3U02D FS+45d | 100% |  |  |  | E3U0240 | E3U0240 | 869 | PU02 | 17 | 2DC9820 | 200 | 200 | 400 | E | DFA | LND | C2 | E | U | EU25 | LUZ2 | 1 | LND | DC | 3A |  |
| E3U0250 |  | PU02 Add. Feed Sys - Vendor dwgs approved | milestone | 0d | 2009-02-21 A | 2009-02-21 A | E3U0240 FF | 100% |  | 1,128,016.4 | 1,128,016.4 | E3U0250 | E3U0250 | 869 | PU02 | 17 | 2DC9820 | 200 | 200 | 400 | E |  | LND | C2 | E | U | EU25 | LUZ2 | 1 | LND | DC |  |  |
| E3U2230 |  | PU22 Vacuum System -Techn. Eval./Bid Tab Final | milestone | 0d | 2009-02-26 A | 2009-02-26 A | E3U2220 FF-15d, E3U2215 SF | 100% |  |  |  | E3U2230 | E3U2230 | 869 | PU22 | 17 | 2DC9170 | 200 | 200 | 055 | E |  | LND | 0 | E | U | EU94 | LUZ2 | 3 | LND |  |  |  |
| E3U0260 |  | PU02 Add. Feed Syst. - 2nd Review Vendor Dwgs |  | 23d | 2009-03-23 A | 2009-04-24 A | E3U0240 FS+20d, E3U0250 | 100% |  |  |  | E3U0260 | E3U0260 | 869 | PU02 | 17 | 2DC9820 | 200 | 200 | 400 | E |  | LND | C2 | E | U | EU25 | LUZ2 | 1 | LND | DC |  |  |
| E3U2240 |  | PU22 Vacuum System - 1st Review dwgs |  | 28d | 2009-08-24 A | 2009-09-30 A | P3U22D1 FS+30d | 100% |  |  |  | E3U2240 | E3U2240 | 869 | PU22 | 17 | 2DC9170 | 200 | 200 | 055 | E |  | LND | 0 | E | U | EU95 | LUZ2 | 3 | LND |  |  |  |
| E3U2250 |  | PU22 Vacuum System - Vendor dwgs approved | milestone | 0d | 2009-09-30 A | 2009-09-30 A | E3U2240 FF | 100% |  | 175,540 | 175,540 | E3U2250 | E3U2250 | 869 | PU22 | 17 | 2DC9170 | 200 | 200 | 055 | E | DFA | LND | 0 | E | U | EU95 | LUZ2 | 3 | LND |  |  |  |
| E3U2260 |  | PU22 Vacuum System - 2nd Review dwgs |  | 172d | 2009-10-16 A | 2010-06-25 A | E3U2250, P3U22D1 FS+60d | 100% | TAA [1600 h] |  |  | E3U2260 | E3U2260 | 869 | PU22 | 17 | 2DC9170 | 200 | 200 | 055 | E |  | LND | 0 | E | U | EU95 | LUZ2 | 3 | LND |  |  | 1600,00 |
| E3U0270 |  | PU02 Add. Feed Syst. - Review Final Documentation |  | 182d | 2010-01-28 A | 2010-10-14 A | P3U02L FF, E3U0260 | 100% | TAA [1200 h] |  |  | E3U0270 | E3U0270 | 869 | PU02 | 17 | 2DC9820 | 200 | 200 | 400 | E |  | LND | C2 | E | U | EU25 | LUZ2 | 1 | LND | DC |  | 1200,00 |
| E3U0275 |  | PU02 Add. Feed Syst. - Loop Folder Review by Instrumentation |  | 20d | 2010-11-12 A | 2010-12-10 A | E3U0270 FS+20d | 100% |  |  |  | E3U0275 | E3U0275 | 869 | PU02 | 17 | 2DC9820 | 200 | 200 | 400 | E |  | LND | C2 | E | U | EU25 | LUZ2 | 1 | LND | DC |  |  |
|  | B | **B Mechanical - Stationary Equipment** |  |  | 2008-03-17 | 2010-11-29 |  |  |  |  |  |  |  |  |  |  |  |  |  |  |  |  |  |  |  |  |  |  |  |  |  |  |  |
| E3ALL220 |  | ALL2 Purge Columns - Techn. Eval./PO Spec. |  | 64d | 2008-03-17 A | 2008-06-18 A | P3ALL2C FF, F7850 | 100% |  |  |  | E3ALL220 | E3ALL220 | 869 | ALL2 | 17 | 2DC8500 | 200 | 200 | 400 | E |  | LND | C2 | E | B | EB44 | LUZ2 | 3 | LND | DC | 3A |  |
| E3A06A10 |  | A06A Electrical Heater - Inquiry Spec. |  | 11d | 2008-04-04 A | 2008-04-18 A | F1670 SS+30d | 100% |  |  |  | E3A06A10 | E3A06A10 | 869 | A06A | 17 | 2DC9080 | 200 | 200 | 055 | E | DEV | LND | 0 | E | B | EB23 | LUZ2 | 3 | LND |  |  |  |
| E3A0820 |  | A08 Vent/Bag Filter - Techn. Eval./PO Spec. |  | 41d | 2008-04-23 A | 2008-06-20 A | P3A08C FF, F5610 | 100% |  |  |  | E3A0820 | E3A0820 | 869 | A08 | 17 | 2DC8560 | 200 | 200 | 400 | E |  | LND | C2 | E | B | EB84 | LUZ2 | 3 | LND | DC | 3A |  |
| E3ALL230 |  | ALL2 Purge Columns -Techn.Eval./Bid Tab Finalize | milestone | 0d | 2008-05-22 A | 2008-05-22 A | E3ALL220 FF-5d, F7940 | 100% |  |  |  | E3ALL230 | E3ALL230 | 869 | ALL2 | 17 | 2DC8500 | 200 | 200 | 055 | E |  | LND | C2 | E | B | EB44 | LUZ2 | 3 | LND |  |  |  |
| E3A0830 |  | A08 Vent/Bag Filter - Techn. Eval./Bid Tab Final | milestone | 0d | 2008-05-31 A | 2008-05-31 A | P3A08C FF-6d, F5690 | 100% |  |  |  | E3A0830 | E3A0830 | 869 | A08 | 17 | 2DC8560 | 200 | 200 | 400 | E |  | LND | C2 | E | B | EB84 | LUZ2 | 3 | LND | DC | 3A |  |
| E3ALL240 |  | ALL2 Purge Columns - 1st Review Vendor Dwgs |  | 11d | 2008-08-22 A | 2008-09-05 A | P3ALL2D FS+30d | 100% |  |  |  | E3ALL240 | E3ALL240 | 869 | ALL2 | 17 | 2DC8500 | 200 | 200 | 400 | E | DFA | LND | C2 | E | B | EB45 | LUZ2 | 3 | LND | DC | 3A |  |
| E3ALL250 |  | ALL2 Purge Columns - Vendor dwgs approved | milestone | 0d | 2008-09-06 A | 2008-09-06 A | E3ALL240 FF | 100% |  | 264,344 | 264,344 | E3ALL250 | E3ALL250 | 869 | ALL2 | 17 | 2DC8500 | 200 | 200 | 400 | E |  | LND | C2 | E | B | EB45 | LUZ2 | 3 | LND | DC |  |  |
| E3A0840 |  | A08 Vent/Bag Filter - 1st Review Vendor Dwgs |  | 9d | 2008-09-08 A | 2008-09-18 A | P3A08D1 FS+20d | 100% |  |  |  | E3A0840 | E3A0840 | 869 | A08 | 17 | 2DC8560 | 200 | 200 | 400 | E | DFA | LND | C2 | E | B | EB85 | LUZ2 | 3 | LND | DC | 3A |  |
| E3A0850 |  | A08 Vent/Bag Filter - Vendor dwgs approved | milestone | 0d | 2008-09-19 A | 2008-09-19 A | E3A0840 FF | 100% |  | 242,800 | 242,800 | E3A0850 | E3A0850 | 869 | A08 | 17 | 2DC8560 | 200 | 200 | 400 | E |  | LND | C2 | E | B | EB85 | LUZ2 | 3 | LND | DC |  |  |
| E3A02B10 |  | A02B Polymer W.Basket - Inquiry Spec. |  | 10d | 2008-10-27 A | 2008-11-10 A | F1670 SS+70d | 100% |  |  |  | E3A02B10 | E3A02B10 | 869 | A02B | 17 | 2DC9840 | 200 | 200 | 055 | E | DEV | LND | 0 | E | B | EB13 | LUZ2 | 3 | LND |  |  |  |
| E3ALL260 |  | ALL2 Purge Columns - 2nd Review Vendor Dwgs |  | 19d | 2008-11-03 A | 2008-11-28 A | E3ALL240 FS+37d, E3ALL250 | 100% |  |  |  | E3ALL260 | E3ALL260 | 869 | ALL2 | 17 | 2DC8500 | 200 | 200 | 400 | E |  | LND | C2 | E | B | EB45 | LUZ2 | 3 | LND | DC |  |  |
| E3A06A20 |  | A06A Electrical Heater - Techn. Eval./PO Spec |  | 304d | 2009-01-06 A | 2010-03-19 A | P3A06AB FS+170d | 100% | TAA [400 h] |  |  | E3A06A20 | E3A06A20 | 869 | A06A | 17 | 2DC9080 | 200 | 200 | 055 | E |  | LND | 0 | E | B | EB24 | LUZ2 | 2 | LND |  |  | 400,00 |
| E3A02B20 |  | A02B Polymer W.Basket - Techn. Eval./PO Spec |  | 378d | 2009-03-02 A | 2010-08-31 A | HEB20 FF, P3A02BB FS+40d | 100% | TAA [160 h] |  |  | E3A02B20 | E3A02B20 | 869 | A02B | 17 | 2DC9840 | 200 | 200 | 055 | E |  | LND | 0 | E | B | EB14 | LUZ2 | 2 | LND |  |  | 160,00 |
| E3A06A40 |  | A06A Electrical Heater - 1st Review dwgs |  | 16d | 2010-04-29 A | 2010-05-21 A | P3A06AL SS+40d | 100% | TAA [720 h] |  |  | E3A06A40 | E3A06A40 | 869 | A06A | 17 | 2DC9080 | 200 | 200 | 055 | E |  | LND | 0 | E | B | EB25 | LUZ2 | 3 | LND |  |  | 720,00 |
| E3A06A50 |  | A06A Electrical Heater - Vendor dwgs approved | milestone | 0d | 2010-05-21 A | 2010-05-21 A | E3A06A40 FF | 100% |  | 15,044 | 15,044 | E3A06A50 | E3A06A50 | 869 | A06A | 17 | 2DC9080 | 200 | 200 | 055 | E | DFA | LND | 0 | E | B | EB25 | LUZ2 | 3 | LND |  |  |  |
| E3A0860 |  | A08 Vent/Bag Filter - Final Review Vendor Dwgs |  | 44d | 2010-06-01 A | 2010-07-30 A | E3A0850, E3A0840 FS+28d | 100% |  |  |  | E3A0860 | E3A0860 | 869 | A08 | 17 | 2DC8560 | 200 | 200 | 400 | E |  | LND | C2 | E | B | EB85 | LUZ2 | 3 | LND | DC |  |  |
| E3A06A60 |  | A06A Electrical Heater - 2nd Review dwgs |  | 13d | 2010-06-28 A | 2010-07-14 A | P3A06AL SS+106d | 100% | TAA [400 h] |  |  | E3A06A60 | E3A06A60 | 869 | A06A | 17 | 2DC9080 | 200 | 200 | 055 | E |  | LND | 0 | E | B | EB25 | LUZ2 | 3 | LND |  |  | 400,00 |
| E3A02B30 |  | A02B Polymer W.Basket - Techn. Eval./Bid Tab F | milestone | 0d | 2010-08-13 A | 2010-08-13 A | E3A02B15 SF, E3A02B20 FF-8d | 100% |  |  |  | E3A02B30 | E3A02B30 | 869 | A02B | 17 | 2DC9840 | 200 | 200 | 055 | E |  | LND | 0 | E | B | EB14 | LUZ2 | 2 | LND |  |  |  |
| E3A02B40 |  | A02B Polymer W.Basket - 1st Review dwgs |  | 11d | 2010-10-13 A | 2010-10-27 A | HEB50 FF, P3A02BL SS+35d | 100% | TAA [400 h] |  |  | E3A02B40 | E3A02B40 | 869 | A02B | 17 | 2DC9840 | 200 | 200 | 055 | E |  | LND | 0 | E | B | EB15 | LUZ2 | 3 | LND |  |  | 400,00 |
| E3A02B50 |  | A02B Polymer W.Basket - Vendor dwgs approved | milestone | 0d | 2010-10-27 A | 2010-10-27 A | E3A02B40 FF | 100% |  | 11,515 | 11,515 | E3A02B50 | E3A02B50 | 869 | A02B | 17 | 2DC9840 | 200 | 200 | 055 | E | DFA | LND | 0 | E | B | EB15 | LUZ2 | 3 | LND |  |  |  |
| E3A02B60 |  | A02B Polymer W.Basket - 2nd Review dwgs |  | 10d | 2010-11-15 A | 2010-11-29 A | E3A02B50, P3A02BL SS+75d | 100% |  |  |  | E3A02B60 | E3A02B60 | 869 | A02B | 17 | 2DC9840 | 200 | 200 | 055 | E |  | LND | 0 | E | B | EB15 | LUZ2 | 3 | LND |  |  |  |

Notes:
- E3U0250: Expenses: 900A 1128016
- E3U2250: Expenses: 900A 175540
- E3ALL250: Expenses: 900A 264344
- E3A0850: Expenses: 900A 242800
- E3A06A50: Expenses: 900A 15044
- E3A02B50: Expenses: 900A 11515

| ID | WBS | Activity | Type | Duration | Start | Finish | Predecessors | Complete | Resources | Cost | Actual cost | UDF_SAVE ACTID | UDF_SAVE ACT ID | Department | Type of Work | Constr. Area | Pro Unit/DocCode | Inquiry/Order No | PMT-Area | PMT-Schedule Org | PMT-Discipline | PMT-Phase | PMT-Stage | PMT-Respons. | Zeigen/n. Zeigen | WBS Phase | WBS Discipline | WBS Type of Work | WBS Objects | IMS | UPT | PMT-Doc. Type | TB26 Ressource Budget |
| --- | --- | --- | --- | --- | --- | --- | --- | --- | --- | --- | --- | --- | --- | --- | --- | --- | --- | --- | --- | --- | --- | --- | --- | --- | --- | --- | --- | --- | --- | --- | --- | --- | --- |
|  | M | **M Mechanical - Rotating Equipment** |  |  | 2008-03-03 | 2011-01-14 |  |  |  |  |  |  |  |  |  |  |  |  |  |  |  |  |  |  |  |  |  |  |  |  |  |  |  |
| E3M0120 |  | M01 Extruder Pck. - Techn. Eval./PO Spec. |  | 38d | 2008-03-03 A | 2008-04-25 A | P3M01C FF, F7220 | 100% |  |  |  | E3M0120 | E3M0120 | 867 | M01 | 17 | DC | 2DC8480 | 200 | 200 | 400 | E | 3A | LND | C2 | E | M | EM34 | LUZ2 | I | LND |  |  |
| E3M1210 |  | M12 Rotary Feeder - Inquiry Spec. |  | 15d | 2008-04-03 A | 2008-04-23 A | F1670 SS | 100% |  |  |  | E3M1210 | E3M1210 | 867 | M12 | 17 |  | 2DC8940 | 200 | 200 | 055 | E |  | LND | 0 | E | M | EM93 | LUZ2 | 3 | LND | DEV |  |
| E3M0130 |  | M01 Extruder Pck. -Techn. Eval./Bid Tab F | milestone | 0d | 2008-04-23 A | 2008-04-23 A | P3M01C FF-4d, F7520 | 100% |  |  |  | E3M0130 | E3M0130 | 867 | M01 | 17 |  | 2DC8480 | 200 | 200 | 055 | E |  | LND | C2 | E | M | EM34 | LUZ2 | I | LND |  |  |
| E3M0140 |  | M01 Extruder Pck. - 1st Review Vendor Dwgs |  | 10d | 2008-05-26 A | 2008-06-06 A | P3M01D FS+18d | 100% |  |  |  | E3M0140 | E3M0140 | 867 | M01 | 17 | DC | 2DC8480 | 200 | 200 | 400 | E | 3A | LND | C2 | E | M | EM35 | LUZ2 | I | LND | DFA |  |
| F7270 |  | M01 Extruder Pck - 1st QA/QC Review Vendor Dwgs |  | 5d | 2008-06-02 A | 2008-06-06 A | E3M0140 FF | 100% |  |  |  | F7270 | F7270 | 867 | M01 | 17 | DC | 2DC8480 | 200 | 200 |  | E |  | LND |  | E | M | EM35 | LUZ2 | 1 | LND |  |  |
| E3M0150 |  | M01 Extruder Pck. - Vendor dwgs approved | milestone | 0d | 2008-06-07 A | 2008-06-07 A | E3M0140 FF | 100% |  | 3,402,040 | 3,402,040 | E3M0150 | E3M0150 | 867 | M01 | 17 | DC | 2DC8480 | 200 | 200 | 400 | E |  | LND | C2 | E | M | EM35 | LUZ2 | I | LND |  |  |
| E3M0160 |  | M01 Extruder Pck. - 2nd Review Vendor Dwgs |  | 15d | 2008-06-23 A | 2008-07-11 A | P3M01D FS+40d, E3M0150 | 100% |  |  |  | E3M0160 | E3M0160 | 867 | M01 | 17 | DC | 2DC8480 | 200 | 200 | 400 | E |  | LND | C2 | E | M | EM35 | LUZ2 | I | LND |  |  |
| F7280 |  | M01 Extruder Pck.- 2nd QA/QC Review Vendor Dwgs |  | 10d | 2008-06-30 A | 2008-07-11 A | E3M0160 FF, F7270, E3M0150 FF | 100% |  |  |  | F7280 | F7280 | 867 | M01 | 17 | DC | 2DC8480 | 200 | 200 |  | E |  | LND |  | E | M | EM35 | LUZ2 | 1 | LND |  |  |
| E3M1220 |  | M12 Rotary Feeder - Techn. Eval./PO Spec |  | 118d | 2008-07-24 A | 2009-01-15 A | P3M12B FS+20d | 100% |  |  |  | E3M1220 | E3M1220 | 867 | M12 | 17 |  | 2DC8940 | 200 | 200 | 055 | E |  | LND | 0 | E | M | EM94 | LUZ2 | 3 | LND |  |  |
| E3M1230 |  | M12 Rotary Feeder -Techn. Eval./Bid Tab F | milestone | 0d | 2008-10-07 A | 2008-10-07 A | E3M1220 FF-6d, E3M1215 SF | 100% |  |  |  | E3M1230 | E3M1230 | 867 | M12 | 17 |  | 2DC8940 | 200 | 200 | 055 | E |  | LND | 0 | E | M | EM94 | LUZ2 | 3 | LND |  |  |
| E3M1240 |  | M12 Rotary Feeder - 1st Review dwgs |  | 23d | 2009-03-23 A | 2009-04-24 A | P3M12D1 FS+25d | 100% |  |  |  | E3M1240 | E3M1240 | 867 | M12 | 17 |  | 2DC8940 | 200 | 200 | 055 | E |  | LND | 0 | E | M | EM95 | LUZ2 | 3 | LND |  |  |
| E3M1250 |  | M12 Rotary Feeder - Vendor dwgs approved | milestone | 0d | 2009-04-24 A | 2009-04-24 A | E3M1240 FF | 100% |  | 155,802 | 155,802 | E3M1250 | E3M1250 | 867 | M12 | 17 |  | 2DC8940 | 200 | 200 | 055 | E |  | LND | 0 | E | M | EM95 | LUZ2 | 3 | LND | DFA |  |
| E3M1260 |  | M12 Rotary Feeder - 2nd Review dwgs |  | 10d | 2009-06-08 A | 2009-06-19 A | P3M12D1 FS+60d, E3M1240 FS+20d | 100% |  |  |  | E3M1260 | E3M1260 | 867 | M12 | 17 |  | 2DC8940 | 200 | 200 | 055 | E |  | LND | 0 | E | M | EM95 | LUZ2 | 3 | LND |  |  |
| E3M0165 |  | M01 Extruder Pck. - Review Rejustment Vendor Dwgs |  | 211d | 2009-11-16 A | 2010-09-17 A | P3M01L1 FS-20d | 100% | TAM [2080 h] |  |  | E3M0165 | E3M0165 | 867 | M01 | 17 | DC | 2DC8480 | 200 | 200 | 400 | E |  | LND | C2 | E | M | EM35 | LUZ2 | I | LND |  | 2080,00 |
| E3M1265 |  | M12 Rotary Feeder - Rejustment Review dwgs |  | 15d | 2009-12-01 A | 2009-12-21 A | E3M1260 FS+115d | 100% | TAM [960 h] |  |  | E3M1265 | E3M1265 | 867 | M12 | 17 |  | 2DC8940 | 200 | 200 | 055 | E |  | LND | 0 | E | M | EM95 | LUZ2 | 3 | LND |  | 960,00 |
| E3M0170 |  | M01 Extruder Pck. - Review Final Documentation |  | 185d | 2010-04-26 A | 2011-01-14 A | P3M01L FF-35d, E3M0165 FF+20d | 100% | TAM [1920 h] |  |  | E3M0170 | E3M0170 | 867 | M01 | 17 | DC | 2DC8480 | 200 | 200 | 400 | E |  | LND | C2 | E | M | EM35 | LUZ2 | 1 | LND |  | 1920,00 |
| E3M0175 |  | M01 Extruder Pck. - Input/Drwgs Oil Unit/PCW Pump/Heat Exchangers |  | 15d | 2010-06-23 A | 2010-07-13 A | E3M0170 SS+40d | 100% |  |  |  | E3M0175 | E3M0175 | 867 | M01 | 17 | DC | 2DC8480 | 200 | 200 | 400 | E |  | LND | C2 | E | M | EM35 | LUZ2 | 1 | LND |  |  |
| E3M0180 |  | M01 Extruder Pck. - Review Instr. Data Sheets / PLC / JB |  | 45d | 2010-06-25 A | 2010-08-26 A | E3M0170 SS+42d | 100% |  |  |  | E3M0180 | E3M0180 | 867 | M01 | 17 | DC | 2DC8480 | 200 | 200 | 400 | E |  | LND | C2 | E | M | EM35 | LUZ2 | 1 | LND |  |  |
|  | 1700 | **1700 Generals - CA17** |  |  | 2009-12-22 | 2011-04-25 |  |  |  |  |  |  |  |  |  |  |  |  |  |  |  |  |  |  |  |  |  |  |  |  |  |  |  |
|  | C | **C Civil** |  |  | 2009-12-22 | 2011-04-25 |  |  |  |  |  |  |  |  |  |  |  |  |  |  |  |  |  |  |  |  |  |  |  |  |  |  |  |
| EC441700 |  | CA17 General - Civil Layout drwgs / Loads IFD | level of effort | 20d | 2009-12-22 A | 2010-01-22 A | EC441770 SS, EC221708 FF, EC221707 FF, EC221707 SS, EC221708 SS | 100% |  |  |  | EC441700 | EC441700 | 87A |  | 17 | 1700C01 |  | 200 |  |  | E |  | LND |  | E | C | EC44 | 1700 | de | LND |  |  |
| EC071705 |  | CA17 General - Issue of working drwgs (AFC) by RDI |  | 294d | 2010-03-01 A | 2011-04-25 A | EC601710 FF, EC48174010 FF, EC601700 FF, EC461710 SS+30d | 100% | TKB-B [45520 h] |  |  | EC071705 | EC071705 | 87A |  | 17 | 1010C13 | 999 | 200 |  |  | E |  | IPR | FL | E | C | EC07 | 1700 | cq | LND |  | 45520,00 |
| EC071700 |  | CA17 General - Check & Release of working drwgs (AFC) |  | 289d | 2010-03-08 A | 2011-04-25 A | EC48174010 FF+5d, EC48173620 FF, EC45170005 SS+30d, EC601700 FF, EC601710 FF | 100% | TKB-B [9480 h] |  |  | EC071700 | EC071700 | 87A |  | 17 |  | 999 | 200 |  |  | E |  | LND | FL | E | C | EC07 | 1700 | cq | LND |  | 9480,00 |
| EC601700 |  | CA17 General - Paving drwgs outside Extr.Bldg AFC |  | 191d | 2010-07-28 A | 2011-04-25 A | EC301700 SS+20d, EC601710 FF, EC120 FF+10d, IMS-E-000120 FF | 100% |  |  |  | EC601700 | EC601700 | 87A |  | 17 | 9617C96 |  | 200 | 200 |  | E |  | IPR |  | E | C | EC60 | 1700 | de | LND |  |  |

Notes:
- E3M0150: Expenses: 900A 3402040
- E3M1250: Expenses: 900A 155802
- EC441700: P3 Activity Log Info: incl. PMT approval

| ID | WBS | Activity | Type | Duration | Start | Finish | Predecessors | Complete | Resources | UDF_SAVE ACTID | UDF_SAVE ACT ID | Department | Constr. Area | PMT-Area | PMT-Schedule Org | PMT-Phase | PMT-Respons. | WBS Phase | WBS Discipline | WBS Type of Work | WBS Objects | IMS | UPT | TB26 Ressource Budget | Type of Work | Inquiry/Order No | PMT-Discipline | Zeigen/n. Zeigen |
| --- | --- | --- | --- | --- | --- | --- | --- | --- | --- | --- | --- | --- | --- | --- | --- | --- | --- | --- | --- | --- | --- | --- | --- | --- | --- | --- | --- | --- |
|  | R | **R Piping** |  |  | 2010-10-04 | 2010-11-05 |  |  |  |  |  |  |  |  |  |  |  |  |  |  |  |  |  |  |  |  |  |  |
| ER441700 |  | CA17 General - Piping Isos (UG) outside ExtrBldg |  | 25d | 2010-10-04 A | 2010-11-05 A | ER440000 FF, IMS-E-000100 FF, EC301700 SS+20d | 100% |  | ER441700 | ER441700 | 876 | 17 | 200 | 200 | E | LND | E | R | ER44 | 1700 | 4 | LND |  |  |  |  |  |
|  | E | **E Electrical** |  |  | 2010-01-26 | 2011-01-18 |  |  |  |  |  |  |  |  |  |  |  |  |  |  |  |  |  |  |  |  |  |  |
| EE761700 |  | CA17 General - Layout Plan Light.& Sockets 1st Issue |  | 249d | 2010-01-26 A | 2011-01-18 A | EE000180 | 100% | TAE [5856 h] | EE761700 | EE761700 | 874 | 17 |  |  | E | LEI | E | E | EE76 | 1700 | E | LND | 5856,00 |  |  |  |  |
|  | 1701 | **1701 Auxiliary/Monorail/Crane Structures - CA17** |  |  | 2008-03-04 | 2011-03-10 |  |  |  |  |  |  |  |  |  |  |  |  |  |  |  |  |  |  |  |  |  |  |
|  | N | **N Structural Steel** |  |  | 2008-03-04 | 2011-03-10 |  |  |  |  |  |  |  |  |  |  |  |  |  |  |  |  |  |  |  |  |  |  |
| EN151701 |  | CA17 Monorail/Crane ins. Extr.Room - CAD Model / Concepts StrSteel |  | 124d | 2008-03-04 A | 2008-08-28 A | AD2230 FF | 100% |  | EN151701 | EN151701 | 87B | 17 |  |  |  | LND | E | N | EN15 | 1701 | de | LND |  | N02M | N02M |  |  |
| EN21170105 |  | CA17 Monorail/Crane ins. Extr.Room - GA-Drwgs + Fdtn Loads |  | 130d | 2009-02-16 A | 2009-08-21 A | EH05171008, EN151701 FF, AD2230 FS+35d, EJ46171005, ER161710, EE46171005 | 100% | TKB-S [64 h] | EN21170105 | EN21170105 | 87B | 17 | 200 |  |  | LND | E | N | EN21 | 1701 | de | LND | 64,00 | N02M | N02M |  |  |
| EN24170105 |  | CA17 Monorail/Crane ins. Extr.Room -StaticCalc f.Fdtn Loads |  | 50d | 2009-09-07 A | 2009-11-13 A | P3C0BD FS+10d, EN21170105 FF+15d | 100% |  | EN24170105 | EN24170105 | 87B | 17 | 200 |  |  | LND | E | N | EN24 | 1701 | de | LND |  | N02M | N02M |  |  |
| EN251701 |  | CA17 Monorail/Crane ins. Extr.Room - Loads for Civil | milestone | 0d | 2009-11-13 A | 2009-11-13 A | EN24170105 FF | 100% |  | EN251701 | EN251701 | 87B | 17 | 200 | 200 | E | LND | E | N | EN25 | 1701 | de | LND |  | N02M | N02M | 055 | 0 |
| EN21170110 |  | CA17 Monorail/Crane ins. Extr.Room - GA-Drwgs + Final Loads |  | 67d | 2009-12-28 A | 2010-04-01 A | EE46171008 FF, EB051710 FS-1d, EJ46171008 FF, EN251701, F4040 SF+5d, EM051710 FF, EN21170105 | 100% | TKB-S [160 h] | EN21170110 | EN21170110 | 87B | 17 | 200 |  |  | LEI | E | N | EN21 | 1701 | de | LND | 160,00 | N02M | N02M |  |  |
| EN24170110 |  | CA17 Monorail/Crane ins. Extr.Room - Final Static Calc |  | 176d | 2010-03-15 A | 2010-11-22 A | EN21170110, ER191710 FF | 100% |  | EN24170110 | EN24170110 | 87B | 17 | 200 |  |  | LEI | E | N | EN24 | 1701 | de | LND |  | N02M | N02M |  |  |
| EN261701 |  | CA17 Monorail/Crane ins. Extr.Room - Layout dwgs input f.KM |  | 92d | 2010-07-22 A | 2010-11-29 A | F4040 FF+20d, EN24170110 FF | 100% | TKB-S [480 h] | EN261701 | EN261701 | 87B | 17 | 200 |  |  | LEI | E | N | EN26 | 1701 | st | LND | 480,00 | N02M | N02M |  |  |
| EN27170105 |  | CA17 Monorail/Crane ins. Extr.Room - KM drwgs |  | 36d | 2010-11-30 A | 2011-01-20 A | EN261701, EN24170105 | 100% | KM Drwgs preparation by Cheljabinsk [35 t] | EN27170105 | EN27170105 | 87B | 17 | 200 |  |  | Chel | E | N | EN27 | 1701 | de | LND | 0,00 | N02M | N02M |  |  |
| EN27170110 |  | CA17 Monorail/Crane ins. Extr.Room - Check KM dwgs |  | 10d | 2011-01-28 A | 2011-02-10 A | EN27170105 FS+5d | 100% |  | EN27170110 | EN27170110 | 87B | 17 | 200 |  |  | LEI | E | N | EN27 | 1701 | de | LND |  | N02M | N02M |  |  |
| EN281701 |  | CA17 Monorail/Crane ins. Extr.Room - Shop dwgs(KMD) by Vend |  | 20d | 2011-02-11 A | 2011-03-10 A | EN27170110 | 100% |  | EN281701 | EN281701 | 87B | 17 | 200 |  |  | Chel | E | N | EN28 | 1701 | de | LND |  | N02M | N02M |  |  |
|  | 1704 | **1704 Internal Pipe Racks - CA17** |  |  | 2008-03-03 | 2011-04-04 |  |  |  |  |  |  |  |  |  |  |  |  |  |  |  |  |  |  |  |  |  |  |
|  | N | **N Structural Steel** |  |  | 2008-03-03 | 2011-04-04 |  |  |  |  |  |  |  |  |  |  |  |  |  |  |  |  |  |  |  |  |  |  |
| EN151704 |  | CA17 SK1704 PR i. Extr.B - CAD Model/Concepts StrSteel |  | 126d | 2008-03-03 A | 2008-08-29 A | AD2230 FF | 100% |  | EN151704 | EN151704 | 87B | 17 | 200 | 200 | E | LND | E | N | EN15 | 1704 | de | LND |  | N02U | N02U | 055 | 0 |
| EN21170405 |  | CA17 SK1704 PR i. Extr.B - GA-Drwgs + Fdtn Loads |  | 120d | 2009-03-16 A | 2009-09-04 A | AD2230 FS+55d, EN151704 FF, ER161704, EN21176005 SS | 100% | TKB-S [320 h] | EN21170405 | EN21170405 | 87B | 17 | 200 |  |  | LND | E | N | EN21 | 1704 | de | LND | 320,00 | N02U | N02U |  |  |
| EN24170405 |  | CA17 SK1704 PR i. Extr.B - Static Calc for Fdtn Loads |  | 19d | 2009-11-09 A | 2009-12-04 A | P3C0BD, EN21170405 | 100% |  | EN24170405 | EN24170405 | 87B | 17 | 200 |  |  | LND | E | N | EN24 | 1704 | de | LND |  | N02U | N02U |  |  |
| EN251704 |  | CA17 SK1704 PR i. Extr.B - Loads for Civil | milestone | 0d | 2009-12-04 A | 2009-12-04 A | EN24170405 FF | 100% |  | EN251704 | EN251704 | 87B | 17 | 200 | 200 | E | LND | E | N | EN25 | 1704 | de | LND |  | N02U | N02U | 055 | 0 |
| EN21170410 |  | CA17 SK1704 PR i. Extr.B - GA-Drwgs + Final Loads |  | 105d | 2009-12-28 A | 2010-05-31 A | EN21170405 FS+10d, EN251704, EN24170405 | 100% | TKB-S [320 h] | EN21170410 | EN21170410 | 87B | 17 | 200 |  |  | LEI | E | N | EN21 | 1704 | de | LND | 320,00 | N02U | N02U |  |  |
| EN24170410 |  | CA17 SK1704 PR i. Extr.B - Final Static Calc |  | 153d | 2010-03-24 A | 2010-10-28 A | ER191704, EN21170410 FF+10d, F4040 SS+10d | 100% |  | EN24170410 | EN24170410 | 87B | 17 | 200 |  |  | LEI | E | N | EN24 | 1704 | de | LND |  | N02U | N02U |  |  |
| EN261704 |  | CA17 SK1704 PR i. Extr.B - Layout dwgs input for KM dwgs |  | 110d | 2010-06-28 A | 2010-11-29 A | F4040 FF+20d, EN24170410 FF | 100% | TKB-S [880 h] | EN261704 | EN261704 | 87B | 17 | 200 |  |  | LEI | E | N | EN26 | 1704 | st | LND | 880,00 | N02U | N02U |  |  |
| EN671704 |  | CA17 SR1704 Int. Piperack - Grating Cut-Out drwgs |  | 59d | 2010-11-05 A | 2011-01-31 A | EN261704 FS-5d, F4462 FF+10d | 100% | TKB-S [240 h] | EN671704 | EN671704 | 87B | 17 | 200 | 200 | C | LEI | E | N | EN67 | 1704 | de | LND | 240,00 | N02U | N02U |  |  |
| EN27170405 |  | CA17 SK1704 PR i. Extr.B - KM drwgs |  | 43d | 2010-12-07 A | 2011-02-07 A | EN24170405, EN261704 FS+5d | 100% | KM Drwgs preparation by Cheljabinsk [189 t] | EN27170405 | EN27170405 | 87B | 17 | 200 |  |  | Chel | E | N | EN27 | 1704 | de | LND | 0,00 | N02U | N02U |  |  |
| EN641704 |  | CA17 SK1704 PR i. Extr.B - Check Grating Cut-Out drwgs |  | 2d | 2010-12-14 A | 2010-12-15 A | EN671704 | 100% |  | EN641704 | EN641704 | 87B | 17 | 200 | 200 | C | LEI | E | N | EN67 | 1704 | de | LND |  | N02U | N02U |  |  |
| EN27170410 |  | CA17 SK1704 PR i. Extr.B - Check KM drwgs |  | 10d | 2011-02-08 A | 2011-02-21 A | EN27170405 | 100% |  | EN27170410 | EN27170410 | 87B | 17 | 200 |  |  | LEI | E | N | EN27 | 1704 | de | LND |  | N02U | N02U |  |  |
| EN281704 |  | CA17 SK1704 PR i. Extr.B - Shop dwgs(KMD) by Vendor |  | 30d | 2011-02-22 A | 2011-04-04 A | EN27170410 | 100% |  | EN281704 | EN281704 | 87B | 17 | 200 |  |  | Chel | E | N | EN28 | 1704 | de | LND |  | N02U | N02U |  |  |

| ID | WBS | Activity | Type | Duration | Start | Finish | Predecessors | Complete | Calendar | Resources | UDF_SAVE ACTID | UDF_SAVE ACT ID | Department | Constr. Area | Inquiry/Order No | PMT-Area | PMT-Respons. | WBS Phase | WBS Discipline | WBS Type of Work | WBS Objects | IMS | UPT | Type of Work | PMT-Schedule Org | PMT-Discipline | PMT-Phase | Zeigen/n. Zeigen | TB26 Ressource Budget |
| --- | --- | --- | --- | --- | --- | --- | --- | --- | --- | --- | --- | --- | --- | --- | --- | --- | --- | --- | --- | --- | --- | --- | --- | --- | --- | --- | --- | --- | --- |
|  | R | **R Piping** |  |  | 2008-04-01 | 2010-07-30 |  |  |  |  |  |  |  |  |  |  |  |  |  |  |  |  |  |  |  |  |  |  |  |
| ER151704 |  | CA17 SK1704 - Conceptual Piping |  | 169d | 2008-04-01 A | 2008-11-28 A | F2760 | 100% |  |  | ER151704 | ER151704 | 876 | 17 | PP | 200 | LND | E | R | ER15 | 1704 | PL | LND |  |  |  |  |  |  |
| ER161704 |  | CA17 SK1704 - prel Loads for Steel Str |  | 20d | 2009-01-05 A | 2009-01-30 A | ER151704 FF | 100% |  |  | ER161704 | ER161704 | 876 | 17 | PP | 200 | LND | E | R | ER16 | 1704 | PL | LND |  |  |  |  |  |  |
| ER191704 |  | CA17 SK1704 - Final Loads for Struc Steel | milestone | 0d | 2010-07-30 A | 2010-07-30 A | ER161704 FF, F4040 FF+50d, EN21170410 SF | 100% |  |  | ER191704 | ER191704 | 876 | 17 | PP | 200 | LNI | E | R | ER19 | 1704 | PL | LND |  |  |  |  |  |  |
|  | 1705 | **1705 Internal Platforms & Frames - CA17** |  |  | 2008-03-03 | 2011-04-15 |  |  |  |  |  |  |  |  |  |  |  |  |  |  |  |  |  |  |  |  |  |  |  |
|  | N | **N Structural Steel** |  |  | 2008-03-03 | 2011-04-15 |  |  |  |  |  |  |  |  |  |  |  |  |  |  |  |  |  |  |  |  |  |  |  |
| EN151705 |  | CA17 SK1705/09/10 Platforms - CAD Model/Concepts StrSteel |  | 126d | 2008-03-03 A | 2008-08-29 A | AD2230 FF | 100% |  |  | EN151705 | EN151705 | 87B | 17 | N02O | 200 | LND | E | N | EN15 | 1705 | de | LND | N02O | 200 | 055 | E | 0 |  |
| EN21170505 |  | CA17 SK1705/09/10 Platforms - GA-Drwgs + Fdtn Loads |  | 120d | 2009-03-16 A | 2009-09-04 A | ER161704, AD2230 FS+55d, EN151705 FF | 100% |  | TKB-S [480 h] | EN21170505 | EN21170505 | 87B | 17 | N02O | 200 | LND | E | N | EN21 | 1705 | de | LND | N02O |  |  |  |  | 480,00 |
| EN24170505 |  | CA17 SK1705/09/10 Platforms - Static Calc for Fdtn Loads |  | 24d | 2009-11-02 A | 2009-12-04 A | P3C0BD, EN21170505 | 100% |  |  | EN24170505 | EN24170505 | 87B | 17 | N02O | 200 | LND | E | N | EN24 | 1705 | de | LND | N02O |  |  |  |  |  |
| EN251705 |  | CA17 SK1705/09/10 Platforms - Loads for Civil | milestone | 0d | 2009-12-04 A | 2009-12-04 A | EN24170505 FF | 100% |  |  | EN251705 | EN251705 | 87B | 17 | N02O | 200 | LND | E | N | EN25 | 1705 | de | LND | N02O | 200 | 055 | E | 0 |  |
| EN21170510 |  | CA17 SK1705/09/10 Platforms - GA-Drwgs + Final Loads |  | 27d | 2009-12-18 A | 2010-01-29 A | EN24170505, EN251705, EN21170505 FS+10d | 100% |  | TKB-S [480 h] | EN21170510 | EN21170510 | 87B | 17 | N02O | 200 | LEI | E | N | EN21 | 1705 | de | LND | N02O |  |  |  |  | 480,00 |
| EN24170510 |  | CA17 SK1705/09/10 Platforms - Final Static Calc |  | 143d | 2010-04-26 A | 2010-11-12 A | EN21170510 | 100% |  |  | EN24170510 | EN24170510 | 87B | 17 | N02O | 200 | LEI | E | N | EN24 | 1705 | de | LND | N02O |  |  |  |  |  |
| EN671705 |  | CA17 SK1705/09/10 Platforms - Grating Cut-Out drwgs |  | 182d | 2010-05-31 A | 2011-02-11 A | F4462 FF+5d, EN261705 | 100% |  | TKB-S [640 h] | EN671705 | EN671705 | 87B | 17 | N02O | 200 | LEI | E | N | EN67 | 1705 | de | LND | N02O | 200 |  | C |  | 640,00 |
| EN261705 |  | CACA17 SK1705/09/10 Platforms - Layout dwgs input for KM dwgs |  | 105d | 2010-06-28 A | 2010-11-22 A | F4040 FF+20d, EN24170510 FF | 100% |  | TKB-S [1200 h] | EN261705 | EN261705 | 87B | 17 | N02O | 200 | LEI | E | N | EN26 | 1705 | st | LND | N02O |  |  |  |  | 1200,00 |
| EN27170505 |  | CA17 SK1705/09/10 Platforms - KM drwgs |  | 67d | 2010-11-23 A | 2011-02-25 A | EN24170505, EN261705 | 100% |  | KM Drwgs preparation by Cheljabinsk [257 t] | EN27170505 | EN27170505 | 87B | 17 | N02O | 200 | Chel | E | N | EN27 | 1705 | de | LND | N02O |  |  |  |  | 0,00 |
| EN641705 |  | CA17 SK1705/09/10 Platforms - Check Grating Cut-Out drwgs |  | 10d | 2011-02-14 A | 2011-02-25 A | EN671705 | 100% |  |  | EN641705 | EN641705 | 87B | 17 | N02O | 200 | LEI | E | N | EN67 | 1705 | de | LND | N02O | 200 |  | C |  |  |
| EN27170510 |  | CA17 SK1705/09/10 Platforms - Check KM drwgs |  | 15d | 2011-02-28 A | 2011-03-18 A | EN27170505 | 100% |  |  | EN27170510 | EN27170510 | 87B | 17 | N02O | 200 | LEI | E | N | EN27 | 1705 | de | LND | N02O |  |  |  |  |  |
| EN281705 |  | CA17 SK1705/09/10 Platforms - Shop dwgs(KMD) by Vendor |  | 20d | 2011-03-21 A | 2011-04-15 A | EN27170510 | 100% |  |  | EN281705 | EN281705 | 87B | 17 | N02O | 200 | Chel | E | N | EN28 | 1705 | de | LND | N02O |  |  |  |  |  |
|  | 1706 | **1706 Cladding Support Structure & Cladding - CA17** |  |  | 2010-03-15 | 2011-04-06 |  |  |  |  |  |  |  |  |  |  |  |  |  |  |  |  |  |  |  |  |  |  |  |
|  | N | **N Structural Steel** |  |  | 2010-03-15 | 2011-04-06 |  |  |  |  |  |  |  |  |  |  |  |  |  |  |  |  |  |  |  |  |  |  |  |
| EN24170610 |  | CA17 SK1706 Cladding Support Str - Final Static Calc |  | 158d | 2010-03-15 A | 2010-10-26 A | EN151711 | 100% |  |  | EN24170610 | EN24170610 | 87B | 17 | N02§ | 200 | LEI | E | N | EN24 | 1706 | de | LND | N02§ |  |  |  |  |  |
| EN801711 |  | CA17 SK1706 Extr Structure - Cladding drwgs |  | 209d | 2010-05-31 A | 2011-02-28 A | ER391718 FF | 100% | TB26 - S - Constr-Sumpf | TKB-S [640 h] | EN801711 | EN801711 | 87B | 17 | N02§ | 200 | SC | E | N | EN80 | 1706 | de | LND | N02§ | 200 |  | C |  | 640,00 |
| EN801702 |  | CA17 SK1706 ExtrBldgEntrHall - Cladding drwgs |  | 191d | 2010-06-21 A | 2011-02-28 A | EN801760 FF | 100% | TB26 - S - Constr-Sumpf | TKB-S [480 h] | EN801702 | EN801702 | 87B | 17 | N02§ | 200 | SC | E | N | EN80 | 1706 | de | LND | N02§ | 200 |  | C |  | 480,00 |
| EN801760 |  | CA17 SK1706 PurgeColStr - Cladding drwgs |  | 191d | 2010-06-21 A | 2011-02-28 A | ER391760 FF | 100% | TB26 - S - Constr-Sumpf | TKB-S [480 h] | EN801760 | EN801760 | 87B | 17 | N02§ | 200 | SC | E | N | EN80 | 1706 | de | LND | N02§ | 200 |  | C |  | 480,00 |
| EN261706 |  | CA17 SK1706 Cladding Support Str - Layout dwgs input f.KM |  | 53d | 2010-09-08 A | 2010-11-22 A | EN24170610 FF+5d | 100% |  |  | EN261706 | EN261706 | 87B | 17 | N02§ | 200 | LEI | E | N | EN26 | 1706 | st | LND | N02§ |  |  |  |  |  |
| EN811760 |  | CA17 SK1706 PurgeColStr - Check Cladding drwgs |  | 25d | 2010-11-19 A | 2010-12-17 A | EN801760 FS+5d | 100% | TB26 - S - Constr-Sumpf |  | EN811760 | EN811760 | 87B | 17 | N02§ | 200 | LEI | E | N | EN81 | 1706 | de | LND | N02§ | 200 |  | C |  |  |
| EN27170605 |  | CA17 SK1706 Cladding Support Str - KM drwgs |  | 42d | 2010-11-23 A | 2011-01-21 A | EN261706, P3N01D FS+10d | 100% |  | KM Drwgs preparation by Cheljabinsk [219 t] | EN27170605 | EN27170605 | 87B | 17 | N02§ | 200 | Chel | E | N | EN27 | 1706 | de | LND | N02§ |  |  |  |  | 0,00 |
| EN27170610 |  | CA17 SK1706 Cladding Support Str - Check KM dwgs |  | 50d | 2010-12-27 A | 2011-03-07 A | EN27170605 FS-15d, EN27170605 FF+5d | 100% |  |  | EN27170610 | EN27170610 | 87B | 17 | N02§ | 200 | LEI | E | N | EN27 | 1706 | de | LND | N02§ |  |  |  |  |  |
| EN271706 |  | CA17 SK1706 Cladding Support Str - Shop dwgs(KMD) by Vendor |  | 35d | 2011-02-17 A | 2011-04-06 A | EN27170610 FF+22d, EN27170610 SS+10d | 100% |  |  | EN271706 | EN271706 | 87B | 17 | N02§ | 200 | Chel | E | N | EN28 | 1706 | de | LND | N02§ |  |  |  |  |  |

| ID | WBS | Activity | Type | Duration | Start | Finish | Predecessors | Complete | Resources | UDF_SAVE ACTID | UDF_SAVE ACT ID | Department | Constr. Area | Pro Unit/DocCode | PMT-Area | PMT-Schedule Org | PMT-Phase | PMT-Respons. | WBS Phase | WBS Discipline | WBS Type of Work | WBS Objects | IMS | UPT | Type of Work | Inquiry/Order No | PMT-Discipline | Zeigen/n. Zeigen | TB26 Ressource Budget |
| --- | --- | --- | --- | --- | --- | --- | --- | --- | --- | --- | --- | --- | --- | --- | --- | --- | --- | --- | --- | --- | --- | --- | --- | --- | --- | --- | --- | --- | --- |
|  | 1707 | **1707 Connection Piperack - CA17 to CA12** |  |  | 2008-03-03 | 2011-02-28 |  |  |  |  |  |  |  |  |  |  |  |  |  |  |  |  |  |  |  |  |  |  |  |
|  | C | **C Civil** |  |  | 2010-01-11 | 2010-07-30 |  |  |  |  |  |  |  |  |  |  |  |  |  |  |  |  |  |  |  |  |  |  |  |
| EC221707 |  | CA17 SR1707 - Layout Drwg / Loads IFD |  | 10d | 2010-01-11 A | 2010-01-22 A | EN251707 | 100% |  | EC221707 | EC221707 | 87A | 17 | 1707C01 | 200 | 200 | E | LND | E | C | EC22 | 1707 | de | LND |  |  |  |  |  |
| EC261707 |  | CA17 SR1707 - Civil Static Calc Fdtn |  | 91d | 2010-02-15 A | 2010-06-25 A | P3C0BD FS+30d, EC221707 FS+15d | 100% |  | EC261707 | EC261707 | 87A | 17 | 1707C14 | 200 | 200 | E | IPR | E | C | EC26 | 1707 | de | LND |  |  |  |  |  |
| EC45170705 |  | CA17 SR1707 - Civil Layout drwgs AFC |  | 106d | 2010-02-15 A | 2010-07-16 A | EC221707 FS+10d, P3C0BD FS+10d, EC261707 SS, AD2230 | 100% |  | EC45170705 | EC45170705 | 87A | 17 | 1707C13 | 200 |  | E | IPR | E | C | EC45 | 1707 | ar | LND |  |  |  |  |  |
| EC151707 |  | CA17 SR1707 - Piling drwgs AFC |  | 42d | 2010-03-08 A | 2010-05-06 A | EC261707 SS+15d | 100% |  | EC151707 | EC151707 | 87A | 17 | 1707C16 | 200 |  |  | IPR | E | C | EC15 | 1707 | PI | LND |  |  |  |  |  |
| EC28170704 |  | CA17 SR1707 - Precast Layout dwgs AFC |  | 86d | 2010-03-29 A | 2010-07-30 A | EC28170710 SS, EC261707 SS+15d | 100% |  | EC28170704 | EC28170704 | 87A | 17 | 1707C31 | 200 | 200 | E | IPR | E | C | EC28 | 1707 | PRE | LND |  |  |  |  |  |
| EC28170710 |  | CA17 SR1707 - Formw/Reinforce drwgs Found. AFC |  | 61d | 2010-03-29 A | 2010-06-25 A | EC45170715 FF, EC261707 SS+10d, EC151707 SS+15d, IMS-E-000150 FF | 100% |  | EC28170710 | EC28170710 | 87A | 17 | 1707C21 | 200 | 200 | E | IPR | E | C | EC28 | 1707 | cq | LND |  |  |  |  |  |
| EC45170715 |  | CA17 SR1707 - Review Civil Layout drwgs |  | 10d | 2010-03-30 A | 2010-04-14 A | EC45170710 | 100% |  | EC45170715 | EC45170715 | 87A | 17 |  | 200 |  | E | LND | E | C | EC45 | 1707 | ar | LND |  |  |  |  |  |
| EC45170710 |  | CA17 SR1707 - Civil Layout drwgs IFC | milestone | 0d | 2010-05-28 A | 2010-05-28 A | EC45170705 FF-14d | 100% |  | EC45170710 | EC45170710 | 87A | 17 |  | 200 |  | E | IPR | E | C | EC45 | 1707 | ar | LND |  |  |  |  |  |
|  | N | **N Structural Steel** |  |  | 2008-03-03 | 2011-02-14 |  |  |  |  |  |  |  |  |  |  |  |  |  |  |  |  |  |  |  |  |  |  |  |
| EN151707 |  | CA17 SR1707 PR outs. - CAD Model/Concepts StrSteel |  | 126d | 2008-03-03 A | 2008-08-29 A | AD2230 FF | 100% |  | EN151707 | EN151707 | 87B | 17 |  | 200 | 200 | E | LND | E | N | EN15 | 1707 | de | LND | N02V | N02V | 055 | 0 |  |
| EN21170705 |  | CA17 SR1707 PR outs. - GA-Drwgs + Fdtn Loads |  | 15d | 2009-03-09 A | 2009-03-27 A | EE46170705, AD2230 FF+30d, EJ46170705, EN151707 FF | 100% |  | EN21170705 | EN21170705 | 87B | 17 |  | 200 |  |  | LND | E | N | EN21 | 1707 | de | LND | N02V | N02V |  |  |  |
| EN24170705 |  | CA17 SR1707 PR outs. - Static Calc for Fdtn Loads |  | 24d | 2009-10-19 A | 2009-11-20 A | P3C0BD FS+10d, EN21170705 FS+10d | 100% | TKB-S [160 h] | EN24170705 | EN24170705 | 87B | 17 |  | 200 |  |  | LEI | E | N | EN24 | 1707 | de | LND | N02V | N02V |  |  | 160,00 |
| EN251707 |  | CA17 SR1707 PR outs. - Loads for Civil | milestone | 0d | 2009-11-20 A | 2009-11-20 A | EN24170705 FF | 100% |  | EN251707 | EN251707 | 87B | 17 |  | 200 | 200 | E | LND | E | N | EN25 | 1707 | de | LND | N02V | N02V | 055 | 0 |  |
| EN21170710 |  | CA17 SR1707 PR outs. - GA-Drwgs + Final Loads |  | 63d | 2009-12-28 A | 2010-03-26 A | EE46170708 FF, EN251707, EN21170705 FS+10d, EN24170705 | 100% | TKB-S [128 h] | EN21170710 | EN21170710 | 87B | 17 |  | 200 |  |  | LEI | E | N | EN21 | 1707 | de | LND | N02V | N02V |  |  | 128,00 |
| EN24170710 |  | CA17 SR1707 PR outs. - Final Static Calc |  | 206d | 2009-12-28 A | 2010-10-19 A | EN21170710 SS, ER191707 FF | 100% | TKB-S [320 h] | EN24170710 | EN24170710 | 87B | 17 |  | 200 |  |  | LEI | E | N | EN24 | 1707 | de | LND | N02V | N02V |  |  | 320,00 |
| EN261707 |  | CA17 SR1707 PR outs. - Layout dwgs input for KM dwgs |  | 115d | 2010-05-10 A | 2010-10-19 A | EN24170710 FF, F4040 FF+20d | 100% | TKB-S [640 h] | EN261707 | EN261707 | 87B | 17 |  | 200 |  |  | LEI | E | N | EN26 | 1707 | st | LND | N02V | N02V |  |  | 640,00 |
| EN671707 |  | CA17 SR1707 PR outs. - Grating Cut-Out drwgs |  | 132d | 2010-06-28 A | 2010-12-30 A | EN261707 FF, ER421707 FF, F4462 FF | 100% | TKB-S [160 h] | EN671707 | EN671707 | 87B | 17 |  | 200 | 200 | C | LEI | E | N | EN67 | 1707 | de | LND | N02V | N02V |  |  | 160,00 |
| EN27170705 |  | CA17 SR1707 PR outs. - KM drwgs |  | 43d | 2010-10-27 A | 2010-12-28 A | EN24170705, EN261707 | 100% | KM Drwgs preparation by Cheljabinsk [71 t] | EN27170705 | EN27170705 | 87B | 17 |  | 200 |  |  | Chel | E | N | EN27 | 1707 | de | LND | N02V | N02V |  |  | 0,00 |
| EN641707 |  | CA17 SR1707 PR outs. - Check Grating Cut-Out drwgs |  | 10d | 2010-12-07 A | 2010-12-20 A | EN671707 | 100% |  | EN641707 | EN641707 | 87B | 17 |  | 200 | 200 | C | LEI | E | N | EN67 | 1707 | de | LND | N02V | N02V |  |  |  |
| EN27170710 |  | CA17 SR1707 PR outs. - Check KM drwgs |  | 8d | 2010-12-29 A | 2011-01-10 A | EN27170705 | 100% |  | EN27170710 | EN27170710 | 87B | 17 |  | 200 |  |  | LEI | E | N | EN27 | 1707 | de | LND | N02V | N02V |  |  |  |
| EN281707 |  | CA17 SR1707 PR outs. - Shop dwgs(KMD) by Vendor |  | 25d | 2011-01-11 A | 2011-02-14 A | EN27170710 | 100% |  | EN281707 | EN281707 | 87B | 17 |  | 200 |  |  | Chel | E | N | EN28 | 1707 | de | LND | N02V | N02V |  |  |  |
|  | R | **R Piping** |  |  | 2008-04-01 | 2011-02-28 |  |  |  |  |  |  |  |  |  |  |  |  |  |  |  |  |  |  |  |  |  |  |  |
| ER151707 |  | CA17 SR1707 - Conceptual Piping |  | 169d | 2008-04-01 A | 2008-11-28 A | F2760 | 100% |  | ER151707 | ER151707 | 876 | 17 |  | 200 |  |  | LND | E | R | ER15 | 1707 | PL | LND |  |  |  |  |  |
| ER301707 |  | CA17 SR1707 - CAD Model Piping / Eqpt |  | 579d | 2008-07-01 A | 2010-10-19 A | ER391707 FF+10d, ER151707 SS | 100% |  | ER301707 | ER301707 | 876 | 17 |  | 200 |  |  | LNI | E | R | ER30 | 1707 | PL | LND |  |  |  |  |  |
| ER161707 |  | CA17 SR1707 - prel Loads for Steel Struc |  | 20d | 2009-01-05 A | 2009-01-30 A | ER151707 FF | 100% |  | ER161707 | ER161707 | 876 | 17 |  | 200 |  |  | LND | E | R | ER16 | 1707 | PL | LND |  |  |  |  |  |
| ER421707 |  | CA17 SR1707 - Stress Calculation |  | 98d | 2009-11-16 A | 2010-04-09 A | HER42 FF, ER361707 | 100% |  | ER421707 | ER421707 | 872 | 17 |  | 200 |  |  | LND | E | R | ER42 | 1707 | PL | LND |  |  |  |  |  |
| ER361707 |  | CA17 SR1707 - CAD Model Review 60% |  | 15d | 2010-03-01 A | 2010-03-19 A | F4040 FF | 100% |  | ER361707 | ER361707 | 876 | 17 |  | 200 |  |  | LND | E | R | ER36 | 1707 | 2 | LND |  |  |  |  |  |
| ER191707 |  | CA17 SR1707 - Final Loads for Steel Struc | milestone | 0d | 2010-07-30 A | 2010-07-30 A | ER161707 FF, F4040 FF+50d, EN21170710 SF-5d | 100% |  | ER191707 | ER191707 | 876 | 17 |  | 200 |  |  | LNI | E | R | ER19 | 1707 | PL | LND |  |  |  |  |  |
| ER391707 |  | CA17 SR1707 - CAD Model Review 90% |  | 10d | 2010-09-06 A | 2010-09-17 A | F4462 FF | 100% |  | ER391707 | ER391707 | 876 | 17 |  | 200 |  |  | LND | E | R | ER39 | 1707 | 3 | LND |  |  |  |  |  |
| ER451707 |  | CA17 SR1707 - Piping Isometrics |  | 59d | 2010-09-27 A | 2010-12-17 A | ER421707, ER391707 FS+5d, ER301707 FF+10d | 100% |  | ER451707 | ER451707 | 876 | 17 |  | 200 |  |  | LEI | E | R | ER45 | 1707 | 5 | LND |  |  |  |  |  |
| ER45170705 |  | CA17 SR1707 - Piping Isometrics (ZEP) |  | 59d | 2010-09-27 A | 2010-12-17 A | ER421707, ER301707 FF+10d, ER391707 FS+5d | 100% |  | ER45170705 | ER45170705 | 876 | 17 |  | 200 |  |  | ZEP | E | R | ER45 | 1707 | 5 | LND |  |  |  |  |  |
| ER441707 |  | CA17 SR1707 - Piping Isometrics (UG) |  | 25d | 2010-10-04 A | 2010-11-05 A | EC301707 SS+20d, ER440000 FF | 100% |  | ER441707 | ER441707 | 876 | 17 |  | 200 | 200 | E | LND | E | R | ER44 | 1707 | 4 | LND |  |  |  |  |  |
| ER49170705 |  | CA17 SR1707 - Design Check/Rel.Isos&BOM ZEP |  | 89d | 2010-10-22 A | 2011-02-28 A | ER451707 SS+10d, ER45170705 SS+10d | 100% |  | ER49170705 | ER49170705 | 876 | 17 |  | 200 |  |  | ZEP | E | R | ER49 | 1707 | 5 | LND |  |  |  |  |  |
| ER491707 |  | CA17 SR1707 - Design Check / Release Isos & BOM |  | 50d | 2010-11-09 A | 2011-01-20 A | ER45170705 FF+20d, ER451707 FF+20d, IMS-E-000110 FF | 100% |  | ER491707 | ER491707 | 876 | 17 |  | 200 |  |  | LEI | E | R | ER49 | 1707 | 5 | LND |  |  |  |  |  |

Notes:
- EC221707: P3 Activity Log Info: TKB-B Keyplan to Subcontractor
- EC45170705: P3 Activity Log Info: incl. PMT approval
- EC45170715: P3 Activity Log Info: incl. PMT approval
- EC45170710: P3 Activity Log Info: incl. PMT approval

| ID | WBS | Activity | Type | Duration | Start | Finish | Predecessors | Complete | Resources | UDF_SAVE ACTID | UDF_SAVE ACT ID | Department | Constr. Area | PMT-Phase | PMT-Respons. | WBS Phase | WBS Discipline | WBS Type of Work | WBS Objects | IMS | UPT | Pro Unit/DocCode | PMT-Area | PMT-Schedule Org | Type of Work | Inquiry/Order No | PMT-Discipline | Zeigen/n. Zeigen | TB26 Ressource Budget |
| --- | --- | --- | --- | --- | --- | --- | --- | --- | --- | --- | --- | --- | --- | --- | --- | --- | --- | --- | --- | --- | --- | --- | --- | --- | --- | --- | --- | --- | --- |
|  | E | **E Electrical** |  |  | 2008-10-06 | 2011-01-21 |  |  |  |  |  |  |  |  |  |  |  |  |  |  |  |  |  |  |  |  |  |  |  |
| EE46170705 |  | CA17 SR1707 - prelim Loads for Struc Steel |  | 15d | 2008-10-06 A | 2008-10-24 A | F3060 FF | 100% |  | EE46170705 | EE46170705 | 874 | 17 | E | LND | E | E | EE11 | 1707 | E | LND |  |  |  |  |  |  |  |  |
| EE901707 |  | CA17 SR1707 - Earthing Details |  | 30d | 2009-04-06 A | 2009-05-20 A | EE901710 SS | 100% |  | EE901707 | EE901707 | 874 | 17 | E | LND | E | E | EE90 | 1707 | E | LND |  |  |  |  |  |  |  |  |
| EE46170710 |  | CA17 SR1707 - El. CableTray Layout Pl. 1st Issue |  | 206d | 2009-12-07 A | 2010-09-30 A | EE460000, F4040 FF+25d | 100% |  | EE46170710 | EE46170710 | 874 | 17 | E | LEI | E | E | EE46 | 1707 | E | LND |  |  |  |  |  |  |  |  |
| EE561707 |  | CA17 SR1707 - Cable Pulling Details |  | 281d | 2009-12-10 A | 2011-01-21 A | EE500130, EE46170710 FF | 100% |  | EE561707 | EE561707 | 874 | 17 | E | LEI | E | E | EE56 | 1707 | E | LND |  |  |  |  |  |  |  |  |
| EE46170708 |  | CA17 SR1707 - Final Loads for Struc Steel |  | 18d | 2010-02-17 A | 2010-03-12 A | EE46170705 | 100% |  | EE46170708 | EE46170708 | 874 | 17 | E | LEI | E | E | EE12 | 1707 | E | LND |  |  |  |  |  |  |  |  |
|  | J | **J Instrumentation** |  |  | 2008-10-06 | 2010-09-30 |  |  |  |  |  |  |  |  |  |  |  |  |  |  |  |  |  |  |  |  |  |  |  |
| EJ46170705 |  | CA17 SR1707 - prelimLoads f.Civil /StrSteel |  | 15d | 2008-10-06 A | 2008-10-24 A | F3060 FF | 100% |  | EJ46170705 | EJ46170705 | 86E | 17 | E | LND | E | J | EJ11 | 1707 | I | LND | 999 |  |  |  |  |  |  |  |
| EJ46170710 |  | CA17 SR1707 - Instr Cable Tray Layout Pl. 1st Issue |  | 150d | 2010-03-01 A | 2010-09-30 A | EE46170710 FF, F4040 FF | 100% |  | EJ46170710 | EJ46170710 | 86E | 17 | E | LEI | E | J | EJ41 | 1707 | I | LND | 999 |  |  |  |  |  |  |  |
|  | 1708 | **1708 Connection Piperack - CA17 to CA13** |  |  | 2008-03-03 | 2011-03-23 |  |  |  |  |  |  |  |  |  |  |  |  |  |  |  |  |  |  |  |  |  |  |  |
|  | C | **C Civil** |  |  | 2010-01-11 | 2010-07-30 |  |  |  |  |  |  |  |  |  |  |  |  |  |  |  |  |  |  |  |  |  |  |  |
| EC221708 |  | CA17 SR1708 - Layout Drwg / Loads IFD |  | 10d | 2010-01-11 A | 2010-01-22 A | EN251708 | 100% |  | EC221708 | EC221708 | 87A | 17 | E | LND | E | C | EC22 | 1708 | de | LND | 1708C01 | 200 | 200 |  |  |  |  |  |
| EC261708 |  | CA17 SR1708 - Civil Static Calc Fdtn |  | 91d | 2010-02-15 A | 2010-06-25 A | P3C0BD FS+30d, EC261707 SS, EC221708 FS+15d | 100% |  | EC261708 | EC261708 | 87A | 17 | E | IPR | E | C | EC26 | 1708 | de | LND | 1708C14 | 200 | 200 |  |  |  |  |  |
| EC45170805 |  | CA17 SR1708 - Civil Layout drwgs AFC |  | 106d | 2010-02-15 A | 2010-07-16 A | EC261708 SS, P3C0BD FS+10d, EC221708, AD2230 | 100% |  | EC45170805 | EC45170805 | 87A | 17 | E | IPR | E | C | EC45 | 1708 | ar | LND | 1708C13 | 200 |  |  |  |  |  |  |
| EC151708 |  | CA17 SR1708 - Piling drwgs AFC |  | 42d | 2010-03-08 A | 2010-05-06 A | EC261708 SS+15d | 100% |  | EC151708 | EC151708 | 87A | 17 |  | IPR | E | C | EC15 | 1708 | PI | LND | 1708C16 | 200 |  |  |  |  |  |  |
| EC28170804 |  | CA17 SR1708 - Precast Layout dwgs AFC |  | 86d | 2010-03-29 A | 2010-07-30 A | EC28170810 SS, EC261708 SS+10d | 100% |  | EC28170804 | EC28170804 | 87A | 17 | E | IPR | E | C | EC28 | 1708 | PRE | LND | 1708C31 | 200 | 200 |  |  |  |  |  |
| EC28170810 |  | CA17 SR1708 - Formw/Reinforce drwgs Found. AFC |  | 61d | 2010-03-29 A | 2010-06-25 A | EC45170815 FF, EC261708 SS+10d, EC151708 SS+15d, IMS-E-000150 FF | 100% |  | EC28170810 | EC28170810 | 87A | 17 | E | IPR | E | C | EC28 | 1708 | cq | LND | 1708C21 | 200 | 200 |  |  |  |  |  |
| EC45170815 |  | CA17 SR1708 - Review Civil Layout drwgs |  | 10d | 2010-03-30 A | 2010-04-14 A | EC45170810 | 100% |  | EC45170815 | EC45170815 | 87A | 17 | E | LND | E | C | EC45 | 1708 | ar | LND |  | 200 |  |  |  |  |  |  |
| EC45170810 |  | CA17 SR1708 - Civil Layout drwgs IFC | milestone | 0d | 2010-05-28 A | 2010-05-28 A | EC45170805 FF-14d | 100% |  | EC45170810 | EC45170810 | 87A | 17 | E | IPR | E | C | EC45 | 1708 | ar | LND |  | 200 |  |  |  |  |  |  |
|  | N | **N Structural Steel** |  |  | 2008-03-03 | 2011-03-23 |  |  |  |  |  |  |  |  |  |  |  |  |  |  |  |  |  |  |  |  |  |  |  |
| EN151708 |  | CA17 SR1708 PR outs. - CAD Model/Concepts StrSteel |  | 126d | 2008-03-03 A | 2008-08-29 A | AD2230 FF | 100% |  | EN151708 | EN151708 | 87B | 17 | E | LND | E | N | EN15 | 1708 | de | LND |  | 200 | 200 | N02W | N02W | 055 | 0 |  |
| EN21170805 |  | CA17 SR1708 PR outs. - GA-Drwgs + Fdtn Loads |  | 15d | 2009-02-23 A | 2009-03-13 A | EE46170805, EJ46170805, ER161708, AD2230 FS+40d, EN151708 | 100% |  | EN21170805 | EN21170805 | 87B | 17 |  | LND | E | N | EN21 | 1708 | de | LND |  | 200 |  | N02W | N02W |  |  |  |
| EN24170805 |  | CA17 SR1708 PR outs. - Static Calc for Fdtn Loads |  | 29d | 2009-10-19 A | 2009-11-27 A | EN21170805 FS+10d, P3C0BD FS+10d | 100% | TKB-S [160 h] | EN24170805 | EN24170805 | 87B | 17 |  | LND | E | N | EN24 | 1708 | de | LND |  | 200 |  | N02W | N02W |  |  | 160,00 |
| EN251708 |  | CA17 SR1708 PR outs. - Loads for Civil | milestone | 0d | 2009-11-27 A | 2009-11-27 A | EN24170805 FF | 100% |  | EN251708 | EN251708 | 87B | 17 | E | LND | E | N | EN25 | 1708 | de | LND |  | 200 | 200 | N02W | N02W | 055 | 0 |  |
| EN21170810 |  | CA17 SR1708 PR outs. - GA-Drwgs + Final Loads |  | 63d | 2009-12-28 A | 2010-03-26 A | EE46170808 FF, EN21170805, EN24170805, EN251708, F4040 SF+10d | 100% | TKB-S [128 h] | EN21170810 | EN21170810 | 87B | 17 |  | LEI | E | N | EN21 | 1708 | de | LND |  | 200 |  | N02W | N02W |  |  | 128,00 |
| EN24170810 |  | CA17 SR1708 PR outs. - Final Static Calc |  | 206d | 2009-12-28 A | 2010-10-19 A | ER191708 FF, EN21170810 SS | 100% | TKB-S [320 h] | EN24170810 | EN24170810 | 87B | 17 |  | LEI | E | N | EN24 | 1708 | de | LND |  | 200 |  | N02W | N02W |  |  | 320,00 |
| EN261708 |  | CA17 SR1708 PR outs. - Layout dwgs input for KM dwgs |  | 115d | 2010-05-10 A | 2010-10-19 A | EN24170810 FF, F4040 FF+20d | 100% | TKB-S [640 h] | EN261708 | EN261708 | 87B | 17 |  | LEI | E | N | EN26 | 1708 | st | LND |  | 200 |  | N02W | N02W |  |  | 640,00 |
| EN671708 |  | CA17 SR1708 PR outs. - Grating Cut-Out drwgs |  | 154d | 2010-05-27 A | 2010-12-30 A | ER421708 FF, F4462 FF, EN261708 FF+10d | 100% | TKB-S [160 h] | EN671708 | EN671708 | 87B | 17 | C | LEI | E | N | EN67 | 1708 | de | LND |  | 200 | 200 | N02W | N02W |  |  | 160,00 |
| EN27170805 |  | CA17 SR1708 PR outs. - KM drwgs |  | 43d | 2010-10-27 A | 2010-12-28 A | EN261708, EN24170805 | 100% | KM Drwgs preparation by Cheljabinsk [71 t] | EN27170805 | EN27170805 | 87B | 17 |  | Chel | E | N | EN27 | 1708 | de | LND |  | 200 |  | N02W | N02W |  |  | 0,00 |
| EN641708 |  | CA17 SR1708 PR outs. - Check Grating Cut-Out drwgs |  | 10d | 2010-12-07 A | 2010-12-20 A | EN671708 | 100% |  | EN641708 | EN641708 | 87B | 17 | C | LEI | E | N | EN67 | 1708 | de | LND |  | 200 | 200 | N02W | N02W |  |  |  |
| EN27170810 |  | CA17 SR1708 PR outs. - Check KM drwgs |  | 8d | 2010-12-29 A | 2011-01-10 A | EN27170805 | 100% |  | EN27170810 | EN27170810 | 87B | 17 |  | LEI | E | N | EN27 | 1708 | de | LND |  | 200 |  | N02W | N02W |  |  |  |
| EN281708 |  | CA17 SR1708 PR outs. - Shop dwgs(KMD) by Vendor |  | 40d | 2011-01-27 A | 2011-03-23 A | EN27170810 FS+12d | 100% |  | EN281708 | EN281708 | 87B | 17 |  | Chel | E | N | EN28 | 1708 | de | LND |  | 200 |  | N02W | N02W |  |  |  |

Notes:
- EC221708: P3 Activity Log Info: TKB-B Keyplan to Subcontractor
- EC45170805: P3 Activity Log Info: incl. PMT approval
- EC45170815: P3 Activity Log Info: incl. PMT approval
- EC45170810: P3 Activity Log Info: incl. PMT / approval

| ID | WBS | Activity | Type | Duration | Start | Finish | Predecessors | Complete | UDF_SAVE ACTID | UDF_SAVE ACT ID | Department | Constr. Area | PMT-Area | PMT-Respons. | WBS Phase | WBS Discipline | WBS Type of Work | WBS Objects | IMS | UPT | PMT-Schedule Org | PMT-Phase | Pro Unit/DocCode |
| --- | --- | --- | --- | --- | --- | --- | --- | --- | --- | --- | --- | --- | --- | --- | --- | --- | --- | --- | --- | --- | --- | --- | --- |
|  | R | **R Piping** |  |  | 2008-04-01 | 2011-02-28 |  |  |  |  |  |  |  |  |  |  |  |  |  |  |  |  |  |
| ER151708 |  | CA17 SR1708 - Conceptual Piping |  | 169d | 2008-04-01 A | 2008-11-28 A | F2760 | 100% | ER151708 | ER151708 | 876 | 17 | 200 | LND | E | R | ER15 | 1708 | PL | LND |  |  |  |
| ER301708 |  | CA17 SR1708 - CAD Model Piping / Eqpt |  | 579d | 2008-07-01 A | 2010-10-19 A | ER391708 FF+10d, ER151708 SS | 100% | ER301708 | ER301708 | 876 | 17 | 200 | LNI | E | R | ER30 | 1708 | PL | LND |  |  |  |
| ER161708 |  | CA17 SR1708 - prel Loads for Steel Struc |  | 20d | 2009-01-05 A | 2009-01-30 A | ER151708 FF | 100% | ER161708 | ER161708 | 876 | 17 | 200 | LND | E | R | ER16 | 1708 | PL | LND |  |  |  |
| ER421708 |  | CA17 SR1708 - Stress Calculation |  | 98d | 2009-11-16 A | 2010-04-09 A | HER42 FF, ER361708 | 100% | ER421708 | ER421708 | 872 | 17 | 200 | LND | E | R | ER42 | 1708 | PL | LND |  |  |  |
| ER361708 |  | CA17 SR1708 - CAD Model Review 60% |  | 15d | 2010-03-01 A | 2010-03-19 A | F4040 FF | 100% | ER361708 | ER361708 | 876 | 17 | 200 | LND | E | R | ER36 | 1708 | 2 | LND |  |  |  |
| ER191708 |  | CA17 SR1708 - Final Loads for Steel Struc | milestone | 0d | 2010-07-30 A | 2010-07-30 A | ER161708 FF, F4040 FF+50d, EN21170810 SF-5d | 100% | ER191708 | ER191708 | 876 | 17 | 200 | LNI | E | R | ER19 | 1708 | PL | LND |  |  |  |
| ER391708 |  | CA17 SR1708 - CAD Model Review 90% |  | 10d | 2010-09-06 A | 2010-09-17 A | F4462 FF | 100% | ER391708 | ER391708 | 876 | 17 | 200 | LND | E | R | ER39 | 1708 | 3 | LND |  |  |  |
| ER451708 |  | CA17 SR1708 - Piping Isometrics |  | 59d | 2010-09-27 A | 2010-12-17 A | ER301708 FF+10d, ER391708 FS+5d, ER421708 | 100% | ER451708 | ER451708 | 876 | 17 | 200 | LEI | E | R | ER45 | 1708 | 5 | LND |  |  |  |
| ER45170805 |  | CA17 SR1708 - Piping Isometrics (ZEP) |  | 59d | 2010-09-27 A | 2010-12-17 A | ER391708 FS+5d, ER421708, ER301708 FF+10d | 100% | ER45170805 | ER45170805 | 876 | 17 | 200 | ZEP | E | R | ER45 | 1708 | 5 | LND |  |  |  |
| ER441708 |  | CA17 SR1708 - Piping Isometrics (UG) |  | 25d | 2010-10-04 A | 2010-11-05 A | EC301708 SS+20d, ER440000 FF | 100% | ER441708 | ER441708 | 876 | 17 | 200 | LND | E | R | ER44 | 1708 | 4 | LND | 200 | E |  |
| ER49170805 |  | CA17 SR1708 - Design Check/Rel.Isos&BOM ZEP |  | 89d | 2010-10-22 A | 2011-02-28 A | ER45170805 SS+10d, ER451708 SS+10d | 100% | ER49170805 | ER49170805 | 876 | 17 | 200 | ZEP | E | R | ER49 | 1708 | 5 | LND |  |  |  |
| ER491708 |  | CA17 SR1708 - Design Check / Release Isos & BOM |  | 50d | 2010-11-09 A | 2011-01-20 A | IMS-E-000110 FF, ER45170805 FF+20d, ER451708 FF+20d | 100% | ER491708 | ER491708 | 876 | 17 | 200 | LEI | E | R | ER49 | 1708 | 5 | LND |  |  |  |
|  | E | **E Electrical** |  |  | 2008-10-06 | 2011-01-21 |  |  |  |  |  |  |  |  |  |  |  |  |  |  |  |  |  |
| EE46170805 |  | CA17 SR1708 - prelim Loads for Struc Steel |  | 15d | 2008-10-06 A | 2008-10-24 A | F3060 FF | 100% | EE46170805 | EE46170805 | 874 | 17 |  | LND | E | E | EE11 | 1708 | E | LND |  | E |  |
| EE901708 |  | CA17 SR1708 - Earthing Details |  | 30d | 2009-04-06 A | 2009-05-20 A | EE901710 SS | 100% | EE901708 | EE901708 | 874 | 17 |  | LND | E | E | EE90 | 1708 | E | LND |  | E |  |
| EE46170810 |  | CA17 SR1708 - El. CableTray Layout Pl. 1st Issue |  | 206d | 2009-12-07 A | 2010-09-30 A | EE460000, F4040 FF+25d | 100% | EE46170810 | EE46170810 | 874 | 17 |  | LEI | E | E | EE46 | 1708 | E | LND |  | E |  |
| EE561708 |  | CA17 SR1708 - Cable Pulling Details |  | 281d | 2009-12-10 A | 2011-01-21 A | EE500130, EE46170810 FF | 100% | EE561708 | EE561708 | 874 | 17 |  | LEI | E | E | EE56 | 1708 | E | LND |  | E |  |
| EE46170808 |  | CA17 SR1708 - Final Loads for Struc Steel |  | 18d | 2010-02-17 A | 2010-03-12 A | EE46170805 | 100% | EE46170808 | EE46170808 | 874 | 17 |  | LEI | E | E | EE12 | 1708 | E | LND |  | E |  |
|  | J | **J Instrumentation** |  |  | 2008-10-06 | 2010-09-30 |  |  |  |  |  |  |  |  |  |  |  |  |  |  |  |  |  |
| EJ46170805 |  | CA17 SR1708 - prelimLoads f.Civil /StrSteel |  | 15d | 2008-10-06 A | 2008-10-24 A | F3060 FF | 100% | EJ46170805 | EJ46170805 | 86E | 17 |  | LND | E | J | EJ11 | 1708 | I | LND |  | E | 999 |
| EJ46170810 |  | CA17 SR1708 - Instr Cable Tray Layout Pl. 1st Issue |  | 150d | 2010-03-01 A | 2010-09-30 A | F4040 FF, EE46170810 FF | 100% | EJ46170810 | EJ46170810 | 86E | 17 |  | LEI | E | J | EJ41 | 1708 | I | LND |  | E | 999 |
|  | 1710 | **1710 Extrusion Bldg 1st Floor +98,650m (+0,15m) - CA17** |  |  | 2008-03-03 | 2011-04-18 |  |  |  |  |  |  |  |  |  |  |  |  |  |  |  |  |  |
|  | 0B | **0B General Activities** |  |  | 2009-01-03 | 2009-01-03 |  |  |  |  |  |  |  |  |  |  |  |  |  |  |  |  |  |
| E0201710 |  | CA17 ExtrBldgFl1 - freeze construction concept | milestone | 0d | 2009-01-03 A | 2009-01-03 A | AD2230 FF | 100% | E0201710 | E0201710 | 87A | 17 | 200 |  | E | 0B | E020 | 1710 | INS | LND |  | E |  |

| ID | WBS | Activity | Type | Duration | Start | Finish | Predecessors | Complete | Planned start | Planned finish | Resources | UDF_SAVE ACTID | UDF_SAVE ACT ID | Department | Constr. Area | PMT-Area | PMT-Respons. | WBS Phase | WBS Discipline | WBS Type of Work | WBS Objects | IMS | UPT | Pro Unit/DocCode | Zeigen/n. Zeigen | PMT-Phase | PMT-Schedule Org | Type of Work | Inquiry/Order No | PMT-Discipline | TB26 Ressource Budget |
| --- | --- | --- | --- | --- | --- | --- | --- | --- | --- | --- | --- | --- | --- | --- | --- | --- | --- | --- | --- | --- | --- | --- | --- | --- | --- | --- | --- | --- | --- | --- | --- |
|  | C | **C Civil** |  |  | 2008-03-03 | 2011-04-11 |  |  |  |  |  |  |  |  |  |  |  |  |  |  |  |  |  |  |  |  |  |  |  |  |  |
| EC421710 |  | CA17 ExtrBldgFl1 - Building Concept |  | 171d | 2008-03-03 A | 2008-11-04 A | F2760 | 100% |  |  |  | EC421710 | EC421710 | 87A | 17 | 200 | LND | E | C | EC42 | 1710 | cq | LND |  |  |  |  |  |  |  |  |
| EC241710 |  | CA17 ExtrBldgFl1 - Fdtn Data Sheets Extruder |  | 40d | 2008-07-28 A | 2008-09-19 A | E3M0140 | 100% |  |  |  | EC241710 | EC241710 | 87A | 17 | 200 | LND | E | C | EC24 | 1710 | de | LND | 1711C01 |  |  |  |  |  |  |  |
| EC26171005 |  | CA17 ExtrBldgFl1 - Predimensioning Extruder Fdtn |  | 66d | 2009-07-01 A | 2009-09-30 A | EC241710 | 100% |  |  |  | EC26171005 | EC26171005 | 87A | 17 | 200 | LND | E | C | EC26 | 1710 | de | LND | 1711C14 | C1 |  |  |  |  |  |  |
| EC441710 |  | CA17 ExtrBldgFl1 - Building Layout drwgs IFD |  | 25d | 2010-01-04 A | 2010-02-05 A | E0201710, EC241710 FF, EC421710, EC221710 FF, AD2230 FF+30d, EC441700 FF | 100% |  |  |  | EC441710 | EC441710 | 87A | 17 | 200 | LND | E | C | EC44 | 1710 | de | LND | 1701C01 |  |  |  |  |  |  |  |
| EC221710 |  | CA17 ExtrBldgFl1 - Civil Foundation Loads |  | 20d | 2010-01-11 A | 2010-02-05 A | EB051718, EN251704 FF, EB051710, EM051718, EN251705 FF, EN251711 FF+5d, EM051710 | 100% |  |  |  | EC221710 | EC221710 | 87A | 17 | 200 | LND | E | C | EC22 | 1710 | de | LND |  |  |  |  |  |  |  |  |
| EC131710 |  | CA17 ExtrBldgFl1 - Fire Safety Survey Report |  | 294d | 2010-01-18 A | 2011-03-14 A | EC461710 SS | 100% |  |  |  | EC131710 | EC131710 | 87A | 17 | 200 | IPR | E | C | EC13 | 1710 | de | LND | 1701C15 |  |  |  |  |  |  |  |
| EC461710 |  | CA17 ExtrBldgFl1 - Civil StaticCalc Basepl |  | 146d | 2010-01-18 A | 2010-08-13 A | P3C0BD FS+20d, EC441710 FF+20d, EN251701 FF | 100% |  |  |  | EC461710 | EC461710 | 87A | 17 | 200 | IPR | E | C | EC46 | 1710 | de | LND | 1701C14 |  |  |  |  |  |  |  |
| EC151710 |  | CA17 ExtrBldgFl1 - Piling drwgs AFC |  | 62d | 2010-02-05 A | 2010-05-05 A | EC461710 SS+14d, EC131710 SS+10d, EC461770 SS | 100% |  |  |  | EC151710 | EC151710 | 87A | 17 | 200 | IPR | E | C | EC15 | 1710 | PI | LND | 1701C16 | C9 |  |  |  |  |  |  |
| EC45170005 |  | CA17 ExtrBldgFl1 - Building Layout drwgs AFC |  | 186d | 2010-02-08 A | 2010-10-29 A | EC441710, AD2230, E3C110 FF, EC131710 FF, EC48100, EC461710 SS | 100% |  |  |  | EC45170005 | EC45170005 | 87A | 17 | 200 | IPR | E | C | EC45 | 1710 | ar | LND | 1701C13 |  | E |  |  |  |  |  |
| EC261710 |  | CA17 ExtrBldgFl1 - Static Calc Extruder Base |  | 234d | 2010-02-12 A | 2011-01-14 A | EC241710, P3C0BD, EC26171005, EC461710 SS | 100% |  |  |  | EC261710 | EC261710 | 87A | 17 | 200 | IPR | E | C | EC26 | 1710 | de | LND | 1711C14 |  |  |  |  |  |  |  |
| EC48171003 |  | CA17 ExtrBldgFl1 - Formw/Reinf drwgs Baseplate AFC |  | 71d | 2010-03-01 A | 2010-06-11 A | EC461710 SS+30d, EC151710 SS+10d | 100% |  |  |  | EC48171003 | EC48171003 | 87A | 17 | 200 | IPR | E | C | EC48 | 1710 | ar | LND | 1701C21 | C9 | E | 200 |  |  |  |  |
| EC701710 |  | CA17 ExtrBldgFl1 - Structural Steel drwgs to 1st Floor input for KM drwgs |  | 79d | 2010-03-08 A | 2010-06-30 A | EC45170005 SS+10d | 100% |  |  |  | EC701710 | EC701710 | 87A | 17 | 200 | IPR | E | C | EC70 | 1710 | de | LND | 1701N51 |  |  |  |  |  |  |  |
| EC48171004 |  | CA17 ExtrBldgFl1 - Precast drwgs AFC |  | 116d | 2010-03-22 A | 2010-09-03 A | EC151710 SS+10d, EC461710 SS+40d | 100% |  |  |  | EC48171004 | EC48171004 | 87A | 17 | 200 | IPR | E | C | EC48 | 1710 | PRE | LND | 1701C31 |  | E | 200 |  |  |  |  |
| EC48171005 |  | CA17 ExtrBldgFl1 - Formw/Reinf drwgs GF +12m AFC - Columns |  | 111d | 2010-03-22 A | 2010-08-27 A | EC48171003 SS+15d, EC461710 SS+30d | 100% |  |  |  | EC48171005 | EC48171005 | 87A | 17 | 200 | IPR | E | C | EC48 | 1710 | ar | LND | 1701C22 | C9 | E | 200 |  |  |  |  |
| EC28171010 |  | CA17 ExtrBldgFl1 - Formw/Reinf drwgs Extr Base AFC |  | 228d | 2010-03-29 A | 2011-02-18 A | EC261710 SS, EC48171003 SS+20d, E3M0175 FF | 100% |  |  |  | EC28171010 | EC28171010 | 87A | 17 | 200 | IPR | E | C | EC28 | 1710 | cq | LND | 1711C21 |  | E | 200 |  |  |  |  |
| EC48171006 |  | CA17 ExtrBldgFl1 - Formw/Reinf drwgs GF +0,00m AFC - Walls,etc. |  | 107d | 2010-04-06 A | 2010-09-03 A | EC48171005 FF+4d | 100% |  |  |  | EC48171006 | EC48171006 | 87A | 17 | 200 | IPR | E | C | EC48 | 1710 | ar | LND | 1701C22 | C9 | E | 200 |  |  |  |  |
| EC48171010 |  | CA17 ExtrBldgFl1 - Precast/Formw/Reinf dwgs Beams/Stairs<12m AFC |  | 106d | 2010-04-14 A | 2010-09-10 A | EC461710 SS+30d, EC48171005 SS+15d | 100% |  |  |  | EC48171010 | EC48171010 | 87A | 17 | 200 | IPR | E | C | EC48 | 1710 | PRE | LND | 1701C54 | C9 | E | 200 |  |  |  |  |
| EC48171020 |  | CA17 ExtrBldgFl1 - Formw/Reinf dwgs Ceiling +12m AFC |  | 117d | 2010-05-14 A | 2010-10-26 A | EC48171005 FF+35d, EH241710 FF | 100% |  |  |  | EC48171020 | EC48171020 | 87A | 17 | 200 | IPR | E | C | EC48 | 1710 | ar | LND | 1701C23 |  | E | 200 |  |  |  |  |
| EC45170010 |  | CA17 ExtrBldgFl1 - Building Layout drwgs IFC | milestone | 0d | 2010-06-15 A | 2010-06-15 A | EC45170005 FF-10d | 100% |  |  |  | EC45170010 | EC45170010 | 87A | 17 | 200 | IPR | E | C | EC45 | 1710 | ar | LND |  |  | E |  |  |  |  |  |
| EC45170015 |  | CA17 ExtrBldgFl1 - Review Building Layout drwgs |  | 100d | 2010-06-21 A | 2010-11-05 A | EC45170005 FF+5d, EC45170010 | 100% |  |  |  | EC45170015 | EC45170015 | 87A | 17 | 200 | LND | E | C | EC45 | 1710 | ar | LND |  |  | E |  |  |  |  |  |
| EC501710 |  | CA17 ExtrBldgFl1 - Architec Detail drwgs Bldg AFC |  | 193d | 2010-07-12 A | 2011-04-11 A | EC48173010 FF, HEC50 FF | 100% |  |  |  | EC501710 | EC501710 | 87A | 17 | 200 | IPR | E | C | EC50 | 1710 | ar | LND | 1701C41 |  | E | 200 |  |  |  |  |
| EC601710 |  | CA17 ExtrBldgFl1 - Paving drwgs (inside) AFC |  | 191d | 2010-07-14 A | 2011-04-11 A | E3M0175 FF, EC301710 SS+20d | 100% |  |  |  | EC601710 | EC601710 | 87A | 17 | 200 | IPR | E | C | EC60 | 1710 | de | LND | 1701C96 |  | E | 200 |  |  |  |  |
|  | N | **N Structural Steel** |  |  | 2008-03-03 | 2011-04-18 |  |  |  |  |  |  |  |  |  |  |  |  |  |  |  |  |  |  |  |  |  |  |  |  |  |
| EN151711 |  | CA17 SK1701 Extr Structure - CAD Model / Concepts StrSteel |  | 126d | 2008-03-03 A | 2008-08-29 A | AD2230 FF | 100% |  |  |  | EN151711 | EN151711 | 87B | 17 | 200 | LND | E | N | EN15 | 1710 | de | LND |  | 0 | E | 200 | N021 | N021 | 055 |  |
| EN21171105 |  | CA17 SK1701 Extr Structure - GA-Drwgs + Fdtn Loads |  | 131d | 2009-02-16 A | 2009-08-24 A | E3U0220 FF, EN151711 FF, EH05173608, AD2230 FS+35d, EJ46171805, EH05173008, EN21176005 SS, EH05171808, EE46171805, EH05174008, ER161718, EH05172008 | 100% |  |  | TKB-S [640 h] | EN21171105 | EN21171105 | 87B | 17 | 200 | LND | E | N | EN21 | 1710 | de | LND |  |  |  |  | N021 | N021 |  | 640,00 |
| EN24171105 |  | CA17 SK1701 Extr Structure -StaticCalc f.Fdtn Loads |  | 69d | 2009-09-14 A | 2009-12-18 A | P3C0BD, EN21171105 | 100% |  |  |  | EN24171105 | EN24171105 | 87B | 17 | 200 | LND | E | N | EN24 | 1710 | de | LND |  |  |  |  | N021 | N021 |  |  |
| EN21171110 |  | CA17 SK1701 Extr Structure - GA-Drwgs + Final Loads |  | 113d | 2009-12-14 A | 2010-05-31 A | EE46171808, EJ46171808 FF, EB051718, EN21171105, EM051718, EN251711 | 100% |  |  | TKB-S [960 h] | EN21171110 | EN21171110 | 87B | 17 | 200 | LEI | E | N | EN21 | 1710 | de | LND |  |  |  |  | N021 | N021 |  | 960,00 |
| EN251711 |  | CA17 SK1701 Extr Structure - Loads for Civil | milestone | 0d | 2009-12-18 A | 2009-12-18 A | EN24171105 FF | 100% |  |  |  | EN251711 | EN251711 | 87B | 17 | 200 | LND | E | N | EN25 | 1710 | de | LND |  | 0 | E | 200 | N021 | N021 | 055 |  |
| EN24171110 |  | CA17 SK1701 Extr Struct - Final Static Calc up to 1st Floor (+112m) |  | 105d | 2010-02-19 A | 2010-07-21 A | EN21171110 SS+30d, ER191718 FF | 100% |  |  |  | EN24171110 | EN24171110 | 87B | 17 | 200 | IPR | E | N | EN24 | 1710 | de | LND |  |  |  |  | N021 | N021 |  |  |
| EN24171115 |  | CA17 SK1701 Extr Structure - Final Static Calc 2nd Floor (+118m) |  | 177d | 2010-02-26 A | 2010-11-05 A | EN24171110 FF+10d | 100% |  |  |  | EN24171115 | EN24171115 | 87B | 17 | 200 | IPR | E | N | EN24 | 1710 | de | LND |  |  |  |  | N022 | N022 |  |  |
| EN24171120 |  | CA17 SK1701 Extr Structure - Final Static Calc 4th Floor (+130m) |  | 177d | 2010-02-26 A | 2010-11-05 A | EN24171130 FF | 100% |  |  |  | EN24171120 | EN24171120 | 87B | 17 | 200 | IPR | E | N | EN24 | 1710 | de | LND |  |  |  |  | N024 | N024 |  |  |
| EN24171130 |  | CA17 SK1701 Extr Structure - Final Static Calc 3rd Floor (+124m) |  | 177d | 2010-02-26 A | 2010-11-05 A | EN24171110 FF+10d | 100% |  |  |  | EN24171130 | EN24171130 | 87B | 17 | 200 | IPR | E | N | EN24 | 1710 | de | LND |  |  |  |  | N023 | N023 |  |  |
| EN24171140 |  | CA17 SK1701 Extr Structure - Final Static Calc 5th Floor (+136m) |  | 177d | 2010-02-26 A | 2010-11-05 A | EN24171120 FF | 100% |  |  |  | EN24171140 | EN24171140 | 87B | 17 | 200 | IPR | E | N | EN24 | 1710 | de | LND |  |  |  |  | N025 | N025 |  |  |
| EN671711 |  | CA17 SK1701 Extr Structure - Grating Cut-Out drwgs |  | 154d | 2010-05-27 A | 2010-12-30 A | ER421740 FF, ER421720 FF, ER421730 FF, ER421736 FF, F4462 FF, EN26171101 FF+10d, ER421718 FF | 100% |  |  | TKB-S [960 h] | EN671711 | EN671711 | 87B | 17 | 200 | LEI | E | N | EN67 | 1710 | de | LND |  |  | C | 200 | N021 | N021 |  | 960,00 |
| EN261711 |  | CA17 SK1701 Extr Structure - Layout dwgs input f.KM all levels |  | 102d | 2010-06-21 A | 2010-11-09 A | EN24171110 FF+5d, F4040 FF+20d | 100% |  |  | TKB-S [2240 h] | EN261711 | EN261711 | 87B | 17 | 200 | LEI | E | N | EN26 | 1710 | st | LND |  |  |  |  | N021 | N021 |  | 2240,00 |
| EN26171101 |  | CA17 SK1701 Extr Structure - Layout dwgs input f.KM up to 1st Floor (+112m) |  | 42d | 2010-06-21 A | 2010-08-17 A | F4040 FF+20d, EN24171110 FF+5d | 100% |  |  |  | EN26171101 | EN26171101 | 87B | 17 | 200 | LEI | E | N | EN26 | 1710 | st | LND |  |  |  |  | N021 | N021 |  |  |
| EN26171105 |  | CA17 SK1701 Extr Structure - Layout dwgs input f.KM 2nd Floor (+118m) |  | 77d | 2010-07-22 A | 2010-11-05 A | EN24171115 FF | 100% |  |  |  | EN26171105 | EN26171105 | 87B | 17 | 200 | LEI | E | N | EN26 | 1710 | st | LND |  |  |  |  | N022 | N022 |  |  |
| EN26171130 |  | CA17 SK1701 Extr Structure - Layout dwgs input f.KM 3rd Floor (+124m) |  | 77d | 2010-07-22 A | 2010-11-05 A | EN24171130 FF | 100% |  |  |  | EN26171130 | EN26171130 | 87B | 17 | 200 | LEI | E | N | EN26 | 1710 | st | LND |  |  |  |  | N023 | N023 |  |  |
| EN26171110 |  | CA17 SK1701 Extr Structure - Layout dwgs input f.KM 4th Floor (+130m) |  | 60d | 2010-08-16 A | 2010-11-05 A | EN24171120 FF | 100% |  |  |  | EN26171110 | EN26171110 | 87B | 17 | 200 | LEI | E | N | EN26 | 1710 | st | LND |  |  |  |  | N024 | N024 |  |  |
| EN27171105 |  | CA17 SK1701 Extr Structure - KM drwgs up to 1st Floor (+112m) |  | 20d | 2010-08-18 A | 2010-09-14 A | EN24171105, EN26171101 | 100% |  |  | KM Drwgs preparation by Cheljabinsk [40 t] | EN27171105 | EN27171105 | 87B | 17 | 200 | Chel | E | N | EN27 | 1710 | de | LND |  |  |  |  | N021 | N021 |  | 0,00 |
| EN26171140 |  | CA17 SK1701 Extr Structure - Layout dwgs input f.KM 5th Floor (+136m) |  | 55d | 2010-08-23 A | 2010-11-05 A | EN24171140 FF | 100% |  |  |  | EN26171140 | EN26171140 | 87B | 17 | 200 | LEI | E | N | EN26 | 1710 | st | LND |  |  |  |  | N025 | N025 |  |  |
| EN27171110 |  | CA17 SK1701 Extr Structure - Check KM dwgs up to 1st Floor (+112m) |  | 5d | 2010-09-15 A | 2010-09-21 A | EN27171105 | 100% |  |  |  | EN27171110 | EN27171110 | 87B | 17 | 200 | LEI | E | N | EN27 | 1710 | de | LND |  |  |  |  | N021 | N021 |  |  |
| EN281711 |  | CA17 SK1701 Extr Structure - Shop dwgs(KMD) by Vendor up to 1st Floor (+112m) |  | 25d | 2010-09-22 A | 2010-10-26 A | EN27171110 | 100% |  |  |  | EN281711 | EN281711 | 87B | 17 | 200 | Chel | E | N | EN28 | 1710 | de | LND |  | C9 |  |  | N021 | N021 |  |  |
| EN27171115 |  | CA17 SK1701 Extr Structure - KM drwgs 2nd Floor (+118m) |  | 20d | 2010-11-08 A | 2010-12-06 A | EN26171105 | 100% |  |  | KM Drwgs preparation by Cheljabinsk [560 t] | EN27171115 | EN27171115 | 87B | 17 | 200 | Chel | E | N | EN27 | 1710 | de | LND |  |  |  |  | N022 | N022 |  | 0,00 |
| EN27171125 |  | CA17 SK1701 Extr Structure - KM drwgs 4th Floor (+130m) |  | 37d | 2010-11-08 A | 2010-12-31 A | EN26171110 | 100% | 2010-11-08 | 2010-12-30 | KM Drwgs preparation by Cheljabinsk [460 t] | EN27171125 | EN27171125 | 87B | 17 | 200 | Chel | E | N | EN27 | 1710 | de | LND |  |  |  |  | N024 | N024 |  | 0,00 |
| EN27171140 |  | CA17 SK1701 Extr Structure - KM drwgs 3rd Floor (+124m) |  | 37d | 2010-11-08 A | 2010-12-31 A | EN26171130 | 100% | 2010-11-08 | 2010-12-30 | KM Drwgs preparation by Cheljabinsk [500 t] | EN27171140 | EN27171140 | 87B | 17 | 200 | Chel | E | N | EN27 | 1710 | de | LND |  |  |  |  | N023 | N023 |  | 0,00 |
| EN27171150 |  | CA17 SK1701 Extr Structure - KM drwgs 5th Floor (+136m) |  | 44d | 2010-11-08 A | 2011-01-11 A | EN26171140 | 100% |  |  | KM Drwgs preparation by Cheljabinsk [280 t] | EN27171150 | EN27171150 | 87B | 17 | 200 | Chel | E | N | EN27 | 1710 | de | LND |  |  |  |  | N025 | N025 |  | 0,00 |
| EN641711 |  | CA17 SK1701 Extr Structure - Check Grating Cut-Out drwgs |  | 10d | 2010-12-14 A | 2010-12-28 A | EN671711 | 100% |  |  |  | EN641711 | EN641711 | 87B | 17 | 200 | LEI | E | N | EN67 | 1710 | de | LND |  |  | C | 200 | N021 | N021 |  |  |
| EN27171120 |  | CA17 SK1701 Extr Structure - Check KM dwgs 2nd Floor (+118m) |  | 10d | 2010-12-21 A | 2011-01-05 A | EN27171115 | 100% |  |  |  | EN27171120 | EN27171120 | 87B | 17 | 200 | LEI | E | N | EN27 | 1710 | de | LND |  |  |  |  | N022 | N022 |  |  |
| EN681711 |  | CA17 SK1701 Extr Structure - Grating Fabrication drwgs |  | 20d | 2010-12-29 A | 2011-01-26 A | EN671711, EN641711 | 100% |  |  |  | EN681711 | EN681711 | 87B | 17 | 200 | SC | E | N | EN68 | 1710 | de | LND |  |  | C | 200 | N021 | N021 |  |  |
| EN27171145 |  | CA17 SK1701 Extr Structure - Check KM dwgs 3rd Floor (+124m) |  | 10d | 2011-01-04 A | 2011-01-17 A | EN27171140 | 100% |  |  |  | EN27171145 | EN27171145 | 87B | 17 | 200 | LEI | E | N | EN27 | 1710 | de | LND |  |  |  |  | N023 | N023 |  |  |
| EN28171105 |  | CA17 SK1701 Extr Structure - Shop dwgs(KMD) by Vendor 2nd Floor (+118m) |  | 25d | 2011-01-06 A | 2011-02-09 A | EN27171120 | 100% |  |  |  | EN28171105 | EN28171105 | 87B | 17 | 200 | Chel | E | N | EN28 | 1710 | de | LND |  | C9 |  |  | N022 | N022 |  |  |
| EN27171130 |  | CA17 SK1701 Extr Structure - Check KM dwgs 4th Floor (+130m) |  | 10d | 2011-01-11 A | 2011-01-24 A | EN27171125, EN27171145 SS+5d | 100% |  |  |  | EN27171130 | EN27171130 | 87B | 17 | 200 | LEI | E | N | EN27 | 1710 | de | LND |  |  |  |  | N024 | N024 |  |  |
| EN27171155 |  | CA17 SK1701 Extr Structure - Check KM dwgs 5th Floor (+136m) |  | 10d | 2011-01-12 A | 2011-01-25 A | EN27171150 | 100% |  |  |  | EN27171155 | EN27171155 | 87B | 17 | 200 | LEI | E | N | EN27 | 1710 | de | LND |  |  |  |  | N025 | N025 |  |  |
| EN28171130 |  | CA17 SK1701 Extr Structure - Shop dwgs(KMD) by Vendor 3rd Floor (+124m) |  | 32d | 2011-01-25 A | 2011-03-09 A | EN27171145 FS+5d | 100% |  |  |  | EN28171130 | EN28171130 | 87B | 17 | 200 | Chel | E | N | EN28 | 1710 | de | LND |  | C9 |  |  | N023 | N023 |  |  |
| EN28171140 |  | CA17 SK1701 Extr Structure - Shop dwgs(KMD) by Vendor 4th Floor (+130m) |  | 40d | 2011-01-25 A | 2011-03-21 A | EN27171130 | 100% |  |  |  | EN28171140 | EN28171140 | 87B | 17 | 200 | Chel | E | N | EN28 | 1710 | de | LND |  | C9 |  |  | N024 | N024 |  |  |
| EN28171150 |  | CA17 SK1701 Extr Structure - Shop dwgs(KMD) by Vendor 5th Floor (+136m) |  | 49d | 2011-02-09 A | 2011-04-18 A | EN27171155 FS+10d | 100% |  |  |  | EN28171150 | EN28171150 | 87B | 17 | 200 | Chel | E | N | EN28 | 1710 | de | LND |  |  |  |  | N025 | N025 |  |  |

Notes:
- EC421710: P3 Activity Log Info: fixed Layout
- EC441710: P3 Activity Log Info: incl. PMT approval
- EC221710: P3 Activity Log Info: TKB-B Keyplan to Subcontractor
- EC45170005: P3 Activity Log Info: incl. PMT approval
- EC45170010: P3 Activity Log Info: incl. PMT / approval
- EC45170015: P3 Activity Log Info: incl. PMT / approval

| ID | WBS | Activity | Type | Duration | Start | Finish | Predecessors | Complete | Resources | UDF_SAVE ACTID | UDF_SAVE ACT ID | Department | Constr. Area | PMT-Phase | PMT-Respons. | WBS Phase | WBS Discipline | WBS Type of Work | WBS Objects | IMS | UPT | PMT-Area | PMT-Schedule Org | PMT-Discipline | TB26 Ressource Budget | Pro Unit/DocCode | Inquiry/Order No |
| --- | --- | --- | --- | --- | --- | --- | --- | --- | --- | --- | --- | --- | --- | --- | --- | --- | --- | --- | --- | --- | --- | --- | --- | --- | --- | --- | --- |
|  | H | **H HVAC** |  |  | 2008-10-06 | 2010-10-07 |  |  |  |  |  |  |  |  |  |  |  |  |  |  |  |  |  |  |  |  |  |
| EH05171008 |  | CA17 ExtrBldgFl1 - prelimLoads f.Civil /StrSteel |  | 15d | 2008-10-06 A | 2008-10-24 A | F3060 FF | 100% |  | EH05171008 | EH05171008 | 87C | 17 | E | LND | E | H | EH11 | 1710 | OTH | LND |  |  |  |  |  |  |
| EH201710 |  | CA17 ExtrBldgFl1 - HVAC&Plumbing / Feed/Basic |  | 198d | 2008-10-06 A | 2009-07-24 A | AD2230 FF+20d | 100% |  | EH201710 | EH201710 | 87C | 17 | E | LND | E | H | EH20 | 1710 | OTH | LND | 200 | 200 | 035 |  |  |  |
| EH30171005 |  | CA17 ExtrBldgFl1 - HVAC Layouts Dwgs AFC |  | 196d | 2009-12-15 A | 2010-09-24 A | EH201710, P3C0BD | 100% | TKB-H [480 h] | EH30171005 | EH30171005 | 87C | 17 | E | IPR | E | H | EH30 | 1710 | OTH | LND | 200 | 200 | 035 | 480,00 | 1701H23 |  |
| EH40171005 |  | CA17 ExtrBldgFl1 - HVAC Calculations&Flow Diagrams |  | 205d | 2009-12-15 A | 2010-10-07 A | EH30171005 SS | 100% | TKB-H [960 h] | EH40171005 | EH40171005 | 87C | 17 | E | IPR | E | H | EH40 | 1710 | OTH | LND | 200 | 200 | 035 | 960,00 | 1701H22 |  |
| EH071710 |  | CA17 ExtrBldgFl1 - Issue of Dwgs&Doc's by RDI | level of effort | 136d | 2010-03-15 A | 2010-09-24 A | EH30171005 SS+60d, EH40171010 FF, EH30171005 FF | 100% | TKB-H [5120 h] | EH071710 | EH071710 | 87C | 17 | E | IPR | E | H | EH30 | 1710 | OTH | LND | 200 | 200 | 035 | 5120,00 |  |  |
| EH30171015 |  | CA17 ExtrBldgFl1 - Review HVAC Layout Dwgs |  | 89d | 2010-05-25 A | 2010-09-24 A | EH30171010 FF-5d | 100% | TKB-H [480 h] | EH30171015 | EH30171015 | 87C | 17 | E | LND | E | H | EH30 | 1710 | OTH | LND | 200 | 200 | 035 | 480,00 |  |  |
| EH30171010 |  | CA17 ExtrBldgFl1 - HVAC Layouts Dwgs IFC | milestone | 0d | 2010-07-12 A | 2010-07-12 A | EH30171005 FF-8d | 100% |  | EH30171010 | EH30171010 | 87C | 17 | E | IPR | E | H | EH30 | 1710 | OTH | LND | 200 | 200 | 035 |  |  |  |
| EH40171010 |  | CA17 ExtrBldgFl1 - HVAC Calc./Diagrams IFC | milestone | 0d | 2010-07-12 A | 2010-07-12 A | EH40171005 FF-8d | 100% |  | EH40171010 | EH40171010 | 87C | 17 | E | IPR | E | H | EH40 | 1710 | OTH | LND | 200 | 200 | 035 |  |  |  |
| EH051710 |  | CA17 ExtrBldgFl1 - Final Loads f.Civil/StrSteel | milestone | 0d | 2010-09-15 A | 2010-09-15 A | E3H0150 SF, EH30171005 FF-8d | 100% |  | EH051710 | EH051710 | 87C | 17 |  | IPR | E | H | EH12 | 1710 | OTH | LND | 200 |  |  |  |  |  |
| EH241710 |  | CA17 ExtrBldgFl1 - Wall&Floor opening details | milestone | 0d | 2010-09-15 A | 2010-09-15 A | E3H0150 SF, EH051710 FF | 100% |  | EH241710 | EH241710 | 87C | 17 | E | IPR | E | H | EH24 | 1710 | OTH | LND | 200 | 200 | 035 |  | 1701H21 |  |
|  | B | **B Mechanical - Stationary Equipment** |  |  | 2008-11-27 | 2008-11-27 |  |  |  |  |  |  |  |  |  |  |  |  |  |  |  |  |  |  |  |  |  |
| EB051710 |  | CA17 ExtrRoom - Final Loads f. Civil/StrSteel | milestone | 0d | 2008-11-27 A | 2008-11-27 A | E3A0120 SF | 100% |  | EB051710 | EB051710 | 869 | 17 |  | LND | E | B | EB05 | 1710 | 3 | LND | 200 |  |  |  |  |  |
|  | M | **M Mechanical - Rotating Equipment** |  |  | 2009-01-24 | 2009-01-24 |  |  |  |  |  |  |  |  |  |  |  |  |  |  |  |  |  |  |  |  |  |
| EM051710 |  | CA17 ExtrRoom - Final Loads f. Civil/StrSteel | milestone | 0d | 2009-01-24 A | 2009-01-24 A | E3M0150 FF | 100% |  | EM051710 | EM051710 | 867 | 17 |  | LND | E | M | EM05 | 1710 | I | LND | 200 |  |  |  |  |  |
|  | R | **R Piping** |  |  | 2008-04-01 | 2011-04-11 |  |  |  |  |  |  |  |  |  |  |  |  |  |  |  |  |  |  |  |  |  |
| ER151710 |  | CA17 ExtrBldgFl1 - Conceptual Piping |  | 169d | 2008-04-01 A | 2008-11-28 A | F2760 | 100% |  | ER151710 | ER151710 | 876 | 17 |  | LND | E | R | ER15 | 1710 | PL | LND | 200 |  |  |  |  |  |
| ER301710 |  | CA17 ExtrBldgFl1 - CAD Model Piping / Eqpt |  | 579d | 2008-07-01 A | 2010-10-19 A | ER151710 SS, ER391710 FF+10d | 100% |  | ER301710 | ER301710 | 876 | 17 |  | LNI | E | R | ER30 | 1710 | PL | LND | 200 |  |  |  |  | 2DC8990 |
| ER161710 |  | CA17 ExtrRoom - prel Loads for Steel Struc |  | 20d | 2009-01-05 A | 2009-01-30 A | ER151710 FF | 100% |  | ER161710 | ER161710 | 876 | 17 |  | LND | E | R | ER16 | 1710 | PL | LND | 200 |  |  |  |  |  |
| ER421710 |  | CA17 ExtrBldgFl1 - Stress Calculation |  | 98d | 2009-11-16 A | 2010-04-09 A | ER361710 | 100% |  | ER421710 | ER421710 | 872 | 17 |  | LND | E | R | ER42 | 1710 | PL | LND | 200 |  |  |  |  | 2DC8990 |
| ER361710 |  | CA17 ExtrBldgFl1 - CAD Model Review 60% |  | 15d | 2010-03-01 A | 2010-03-19 A | F4040 FF | 100% |  | ER361710 | ER361710 | 876 | 17 |  | LND | E | R | ER36 | 1710 | 2 | LND | 200 |  |  |  |  | 2DC8990 |
| ER191710 |  | CA17 ExtrRoom - Final Loads for Steel Struc | milestone | 0d | 2010-07-30 A | 2010-07-30 A | EN21170110 SF, F4040 FF+50d, ER161710 FF | 100% |  | ER191710 | ER191710 | 876 | 17 |  | LNI | E | R | ER19 | 1710 | PL | LND | 200 |  |  |  |  |  |
| ER391710 |  | CA17 ExtrBldgFl1 - CAD Model Review 90% |  | 10d | 2010-09-06 A | 2010-09-17 A | F4462 FF | 100% |  | ER391710 | ER391710 | 876 | 17 |  | LND | E | R | ER39 | 1710 | 3 | LND | 200 |  |  |  |  | 2DC8990 |
| ER451710 |  | CA17 ExtrBldgFl1 - Piping Isometrics |  | 59d | 2010-09-27 A | 2010-12-17 A | ER391710 FS+5d, ER301710 FF+10d, ER421710 | 100% |  | ER451710 | ER451710 | 876 | 17 |  | LEI | E | R | ER45 | 1710 | 5 | LND | 200 |  |  |  |  |  |
| ER45171005 |  | CA17 ExtrBldgFl1 - Piping Isometrics (ZEP) |  | 59d | 2010-09-27 A | 2010-12-17 A | ER301710 FF+10d, ER391710 FS+5d, ER421710 | 100% |  | ER45171005 | ER45171005 | 876 | 17 |  | ZEP | E | R | ER45 | 1710 | 5 | LND | 200 |  |  |  |  |  |
| ER441710 |  | CA17 ExtrBldgFl1 - Piping Isometrics (UG) |  | 25d | 2010-10-04 A | 2010-11-05 A | IMS-E-000100 FF, EC301710 SS+20d, ER440000 FF | 100% |  | ER441710 | ER441710 | 876 | 17 | E | LND | E | R | ER44 | 1710 | 4 | LND | 200 | 200 |  |  |  |  |
| ER49171005 |  | CA17 ExtrBldgFl1 - Design Check/Rel.Isos&BOM ZEP |  | 94d | 2010-10-15 A | 2011-02-28 A | ER451710 SS+10d, ER45171005 SS+10d | 100% |  | ER49171005 | ER49171005 | 876 | 17 |  | ZEP | E | R | ER49 | 1710 | 5 | LND | 200 |  |  |  |  | 2DC8990 |
| ER491710 |  | CA17 ExtrBldgFl1 - Design Check/ Rel.Isos&BOM |  | 107d | 2010-11-09 A | 2011-04-11 A | ER45171005 FF+20d, ER451710 FF+20d | 100% |  | ER491710 | ER491710 | 876 | 17 |  | LEI | E | R | ER49 | 1710 | 5 | LND | 200 |  |  |  |  | 2DC8990 |

| ID | WBS | Activity | Type | Duration | Start | Finish | Predecessors | Complete | Resources | UDF_SAVE ACTID | UDF_SAVE ACT ID | Department | Constr. Area | PMT-Phase | PMT-Respons. | WBS Phase | WBS Discipline | WBS Type of Work | WBS Objects | IMS | UPT | TB26 Ressource Budget | Pro Unit/DocCode | PMT-Area | PMT-Schedule Org | PMT-Discipline |
| --- | --- | --- | --- | --- | --- | --- | --- | --- | --- | --- | --- | --- | --- | --- | --- | --- | --- | --- | --- | --- | --- | --- | --- | --- | --- | --- |
|  | E | **E Electrical** |  |  | 2008-10-06 | 2011-02-14 |  |  |  |  |  |  |  |  |  |  |  |  |  |  |  |  |  |  |  |  |
| EE46171005 |  | CA17 ExtrBldgFl1 - prelimLoads f.Civil /StrSteel |  | 15d | 2008-10-06 A | 2008-10-24 A | F3060 FF | 100% |  | EE46171005 | EE46171005 | 874 | 17 | E | LND | E | E | EE11 | 1710 | E | LND |  |  |  |  |  |
| EE901710 |  | CA17 ExtrBldgFl1 - Earthing Details |  | 30d | 2009-04-06 A | 2009-05-20 A | EE903110 | 100% |  | EE901710 | EE901710 | 874 | 17 | E | LND | E | E | EE90 | 1710 | E | LND |  |  |  |  |  |
| EE46171010 |  | CA17 ExtrBldgFl1 - El. CableTray Layout Pl. / LOP's 1st Issue |  | 206d | 2009-12-07 A | 2010-09-30 A | EE460000, F4040 FF+25d | 100% | TAE [4800 h] | EE46171010 | EE46171010 | 874 | 17 | E | LEI | E | E | EE46 | 1710 | E | LND | 4800,00 |  |  |  |  |
| EE561710 |  | CA17 ExtrBldgFl1 - Cable Pulling Details |  | 297d | 2009-12-10 A | 2011-02-14 A | EE500130, EE46171010 FF | 100% | TAE [22016 h] | EE561710 | EE561710 | 874 | 17 | E | LEI | E | E | EE56 | 1710 | E | LND | 22016,00 |  |  |  |  |
| EE46171008 |  | CA17 ExtrRoom - Final Loads f.Civil /StrSteel |  | 20d | 2010-02-15 A | 2010-03-12 A | EE46171005 | 100% |  | EE46171008 | EE46171008 | 874 | 17 | E | LEI | E | E | EE12 | 1710 | E | LND |  |  |  |  |  |
|  | J | **J Instrumentation** |  |  | 2008-10-06 | 2011-02-07 |  |  |  |  |  |  |  |  |  |  |  |  |  |  |  |  |  |  |  |  |
| EJ46171005 |  | CA17 ExtrRoom - prelimLoads f.Civil /StrSteel |  | 15d | 2008-10-06 A | 2008-10-24 A | F3060 FF | 100% |  | EJ46171005 | EJ46171005 | 86E | 17 | E | LND | E | J | EJ11 | 1710 | I | LND |  | 999 |  |  |  |
| EJ361710 |  | CA17 ExtrBldgFl1 - Hook-Up drwgs 1st Issue |  | 99d | 2010-02-08 A | 2010-06-30 A | F4040 FF+55d, A1EJ0080 | 100% |  | EJ361710 | EJ361710 | 86E | 17 | C | LEI | E | J | EJ36 | 1710 | I | LND |  | 999 | 200 | 200 |  |
| EJ46171008 |  | CA17 ExtrRoom - Final Loads f.Civil /StrSteel |  | 10d | 2010-03-01 A | 2010-03-12 A | EJ46171005 | 100% |  | EJ46171008 | EJ46171008 | 86E | 17 | E | LEI | E | J | EJ12 | 1710 | I | LND |  | 999 |  |  |  |
| EJ46171010 |  | CA17 ExtrBldgFl1 - Instr Cable Tray Layout Pl 1st Issue |  | 150d | 2010-03-01 A | 2010-09-30 A | EE46171010 FF, F4040 FF | 100% | TAP [2800 h] | EJ46171010 | EJ46171010 | 86E | 17 | E | LEI | E | J | EJ41 | 1710 | I | LND | 2800,00 | 999 |  |  |  |
| EJ32171005 |  | General - JB Location drwgs |  | 182d | 2010-05-25 A | 2011-02-07 A | F4468 FF-20d, F4040, F4462 FF+20d, F4465 FF+10d | 100% | TAP [10240 h] | EJ32171005 | EJ32171005 | 86E | 17 | C | LEI | E | J | EJ37 | 1710 | I | LND | 10240,00 | 999 | 200 | 200 |  |
| EJ800000 |  | General - Loop Diagrams |  | 136d | 2010-07-21 A | 2011-01-31 A | EJ801710 FF, EJ800010 | 100% | TAP [14080 h] | EJ800000 | EJ800000 | 86E | 17 | E | LEI | E | J | EJ80 | 1710 | I | LND | 14080,00 | 999 |  |  |  |
| EJ801710 |  | CA17 ExtrBldgFl1 - Loop Diagrams |  | 79d | 2010-08-20 A | 2010-12-09 A | EJ800010, A1EJ0040 FF | 100% |  | EJ801710 | EJ801710 | 86E | 17 | E | LEI | E | J | EJ80 | 1710 | I | LND |  | 999 |  |  |  |
| EJ321710 |  | CA17 ExtrBldgFl1 - JB Location drwgs |  | 72d | 2010-09-06 A | 2010-12-15 A | F4040, F4462 FF+20d | 100% |  | EJ321710 | EJ321710 | 86E | 17 | C | LEI | E | J | EJ37 | 1710 | I | LND |  | 999 | 200 | 200 |  |
|  | 1718 | **1718 Extrusion Bldg 2nd Floor +111,250m (+12,75m) - CA17** |  |  | 2008-04-01 | 2011-04-11 |  |  |  |  |  |  |  |  |  |  |  |  |  |  |  |  |  |  |  |  |
|  | 0B | **0B General Activities** |  |  | 2009-01-03 | 2009-01-03 |  |  |  |  |  |  |  |  |  |  |  |  |  |  |  |  |  |  |  |  |
| E0201718 |  | CA17 ExtrBldgFl2 - freeze construction concept | milestone | 0d | 2009-01-03 A | 2009-01-03 A | AD2230 FF | 100% |  | E0201718 | E0201718 | 87A | 17 | E |  | E | 0B | E020 | 1718 | INS | LND |  |  | 200 |  |  |
|  | C | **C Civil** |  |  | 2010-06-30 | 2010-11-16 |  |  |  |  |  |  |  |  |  |  |  |  |  |  |  |  |  |  |  |  |
| EC48171810 |  | CA17 ExtrBldgFl2 - Precast/Formw/Reinf dwgs Stairtowers <18m East/South AFC |  | 53d | 2010-06-30 A | 2010-09-10 A | EC48171010 FF | 100% |  | EC48171810 | EC48171810 | 87A | 17 | E | IPR | E | C | EC48 | 1718 | PRE | LND |  | 1701C55 | 200 | 200 |  |
| EC48171820 |  | CA17 ExtrBldgFl2 - Formw/Reinf drwgs Ceiling+18m AFC |  | 77d | 2010-08-02 A | 2010-11-16 A | EH241718 FF, EC48171020 FF+10d, EC48171810 FF | 100% |  | EC48171820 | EC48171820 | 87A | 17 | E | IPR | E | C | EC48 | 1718 | ar | LND |  | 1701C24 | 200 | 200 |  |
|  | H | **H HVAC** |  |  | 2008-10-06 | 2010-09-24 |  |  |  |  |  |  |  |  |  |  |  |  |  |  |  |  |  |  |  |  |
| EH05171808 |  | CA17 ExtrBldgFl2 - prelimLoads f.Civil /StrSteel |  | 15d | 2008-10-06 A | 2008-10-24 A | F3060 FF | 100% |  | EH05171808 | EH05171808 | 87C | 17 | E | LND | E | H | EH11 | 1718 | OTH | LND |  |  |  |  |  |
| EH201718 |  | CA17 ExtrBldgFl2 - HVAC&Plumbing / Feed/Basic |  | 198d | 2008-10-06 A | 2009-07-24 A | AD2230 FF+20d | 100% |  | EH201718 | EH201718 | 87C | 17 | E | LND | E | H | EH20 | 1718 | OTH | LND |  |  | 200 | 200 | 035 |
| EH30171805 |  | CA17 ExtrBldgFl2 - HVAC Layouts Dwgs AFC |  | 196d | 2009-12-15 A | 2010-09-24 A | EH30171005 SS, EH201718 | 100% | TKB-H [480 h] | EH30171805 | EH30171805 | 87C | 17 | E | IPR | E | H | EH30 | 1718 | OTH | LND | 480,00 |  | 200 | 200 | 035 |
| EH071718 |  | CA17 ExtrBldgFl2 - Issue of Dwgs&Doc's by RDI | level of effort | 136d | 2010-03-15 A | 2010-09-24 A | EH30171805 SS+60d, EH30171805 FF | 100% | TKB-H [5120 h] | EH071718 | EH071718 | 87C | 17 | E | IPR | E | H | EH30 | 1718 | OTH | LND | 5120,00 |  | 200 | 200 | 035 |
| EH30171815 |  | CA17 ExtrBldgFl2 - Review HVAC Layout Dwgs |  | 89d | 2010-05-25 A | 2010-09-24 A | EH30171810 FF-5d | 100% | TKB-H [480 h] | EH30171815 | EH30171815 | 87C | 17 | E | LND | E | H | EH30 | 1718 | OTH | LND | 480,00 |  | 200 | 200 | 035 |
| EH30171810 |  | CA17 ExtrBldgFl2 - HVAC Layouts Dwgs IFC | milestone | 0d | 2010-07-12 A | 2010-07-12 A | EH30171805 FF-8d | 100% |  | EH30171810 | EH30171810 | 87C | 17 | E | IPR | E | H | EH30 | 1718 | OTH | LND |  |  | 200 | 200 | 035 |
| EH051718 |  | CA17 ExtrBldgFl2 - Final Loads f. StrSteel | milestone | 0d | 2010-09-15 A | 2010-09-15 A | E3H0150 SF, EH30171805 FF-8d | 100% |  | EH051718 | EH051718 | 87C | 17 |  | IPR | E | H | EH12 | 1718 | OTH | LND |  |  | 200 |  |  |
| EH241718 |  | CA17 ExtrBldgFl2 - Wall&Floor opening details | milestone | 0d | 2010-09-15 A | 2010-09-15 A | EH051718 FF, E3H0150 SF | 100% |  | EH241718 | EH241718 | 87C | 17 | E | IPR | E | H | EH24 | 1718 | OTH | LND |  |  | 200 | 200 | 035 |

Notes:
- EE561710: P3 Activity Log Info: UG/Above Ground Details

| ID | WBS | Activity | Type | Duration | Start | Finish | Predecessors | Complete | Resources | UDF_SAVE ACTID | UDF_SAVE ACT ID | Department | Constr. Area | PMT-Area | PMT-Respons. | WBS Phase | WBS Discipline | WBS Type of Work | WBS Objects | IMS | UPT | PMT-Phase | TB26 Ressource Budget | Pro Unit/DocCode | PMT-Schedule Org |
| --- | --- | --- | --- | --- | --- | --- | --- | --- | --- | --- | --- | --- | --- | --- | --- | --- | --- | --- | --- | --- | --- | --- | --- | --- | --- |
|  | B | **B Mechanical - Stationary Equipment** |  |  | 2008-11-04 | 2008-11-04 |  |  |  |  |  |  |  |  |  |  |  |  |  |  |  |  |  |  |  |
| EB051718 |  | CA17 ExtrStruc - Final Loads for Struc Steel | milestone | 0d | 2008-11-04 A | 2008-11-04 A | E3U0220 FF | 100% |  | EB051718 | EB051718 | 869 | 17 | 200 | LND | E | B | EB05 | 1718 | 3 | LND |  |  |  |  |
|  | M | **M Mechanical - Rotating Equipment** |  |  | 2009-01-24 | 2009-01-24 |  |  |  |  |  |  |  |  |  |  |  |  |  |  |  |  |  |  |  |
| EM051718 |  | CA17 ExtrStruc - Final Loads for Struc Steel | milestone | 0d | 2009-01-24 A | 2009-01-24 A | E3M0150 FF, E3U2250 FF, E3U0250 FF | 100% |  | EM051718 | EM051718 | 867 | 17 | 200 | LND | E | M | EM05 | 1718 | I | LND |  |  |  |  |
|  | R | **R Piping** |  |  | 2008-04-01 | 2011-04-11 |  |  |  |  |  |  |  |  |  |  |  |  |  |  |  |  |  |  |  |
| ER151718 |  | CA17 ExtrBldgFl2 - Conceptual Piping |  | 169d | 2008-04-01 A | 2008-11-28 A | F2760 | 100% |  | ER151718 | ER151718 | 876 | 17 | 200 | LND | E | R | ER15 | 1718 | PL | LND |  |  |  |  |
| ER301718 |  | CA17 ExtrBldgFl2 - CAD Model Piping / Eqpt |  | 579d | 2008-07-01 A | 2010-10-19 A | ER151718 SS, ER391718 FF+10d, E0201718 FF | 100% |  | ER301718 | ER301718 | 876 | 17 | 200 | LNI | E | R | ER30 | 1718 | PL | LND |  |  |  |  |
| ER161718 |  | CA17 ExtrStruc - prel Loads for Steel Struc |  | 20d | 2009-01-05 A | 2009-01-30 A | ER151718 FF | 100% |  | ER161718 | ER161718 | 876 | 17 | 200 | LND | E | R | ER16 | 1718 | PL | LND |  |  |  |  |
| ER421718 |  | CA17 ExtrBldgFl2 - Stress Calculation |  | 98d | 2009-11-16 A | 2010-04-09 A | ER361718 | 100% |  | ER421718 | ER421718 | 872 | 17 | 200 | LND | E | R | ER42 | 1718 | PL | LND |  |  |  |  |
| ER361718 |  | CA17 ExtrBldgFl2 - CAD Model Review 60% |  | 15d | 2010-03-01 A | 2010-03-19 A | F4040 FF | 100% |  | ER361718 | ER361718 | 876 | 17 | 200 | LND | E | R | ER36 | 1718 | 2 | LND |  |  |  |  |
| ER191718 |  | CA17 ExtrStruc - Final Loads for Steel Struc | milestone | 0d | 2010-07-30 A | 2010-07-30 A | EN21171110 SF, ER161718 FF, F4040 FF+50d | 100% |  | ER191718 | ER191718 | 876 | 17 | 200 | LNI | E | R | ER19 | 1718 | PL | LND |  |  |  |  |
| ER391718 |  | CA17 ExtrBldgFl2 - CAD Model Review 90% |  | 10d | 2010-09-06 A | 2010-09-17 A | F4462 FF | 100% |  | ER391718 | ER391718 | 876 | 17 | 200 | LND | E | R | ER39 | 1718 | 3 | LND |  |  |  |  |
| ER451718 |  | CA17 ExtrBldgFl2 - Piping Isometrics |  | 59d | 2010-09-27 A | 2010-12-17 A | ER301718 FF+10d, ER421718, ER391718 FS+5d | 100% |  | ER451718 | ER451718 | 876 | 17 | 200 | LEI | E | R | ER45 | 1718 | 5 | LND |  |  |  |  |
| ER45171805 |  | CA17 ExtrBldgFl2 - Piping Isometrics (ZEP) |  | 59d | 2010-09-27 A | 2010-12-17 A | ER391718 FS+5d, ER301718 FF+10d, ER421718 | 100% |  | ER45171805 | ER45171805 | 876 | 17 | 200 | ZEP | E | R | ER45 | 1718 | 5 | LND |  |  |  |  |
| ER49171805 |  | CA17 ExtrBldgFl2 - Design Check/Rel.Isos&BOM ZEP |  | 94d | 2010-10-15 A | 2011-02-28 A | ER45171805 SF+10d, ER451718 SS+10d | 100% |  | ER49171805 | ER49171805 | 876 | 17 | 200 | ZEP | E | R | ER49 | 1718 | 5 | LND |  |  |  |  |
| ER491718 |  | CA17 ExtrBldgFl2 - Design Check/ Rel.Isos&BOM |  | 107d | 2010-11-09 A | 2011-04-11 A | ER451718 FF+20d, ER45171805 FF+20d, IMS-E-000110 FF | 100% |  | ER491718 | ER491718 | 876 | 17 | 200 | LEI | E | R | ER49 | 1718 | 5 | LND |  |  |  |  |
|  | E | **E Electrical** |  |  | 2008-10-06 | 2011-02-14 |  |  |  |  |  |  |  |  |  |  |  |  |  |  |  |  |  |  |  |
| EE46171805 |  | CA17 ExtrBldg - prelimLoads f.Civil /StrSteel |  | 15d | 2008-10-06 A | 2008-10-24 A | F3060 FF | 100% |  | EE46171805 | EE46171805 | 874 | 17 |  | LND | E | E | EE11 | 1718 | E | LND | E |  |  |  |
| EE901718 |  | CA17 ExtrBldgFl2 - Earthing Details |  | 30d | 2009-04-06 A | 2009-05-20 A | EE901710 SS | 100% |  | EE901718 | EE901718 | 874 | 17 |  | LND | E | E | EE90 | 1718 | E | LND | E |  |  |  |
| EE46171810 |  | CA17 ExtrBldgFl2 - El. CableTray Layout Pl. / LOP's 1st Issue |  | 217d | 2009-12-07 A | 2010-10-15 A | F4040 FF+25d, EE460000 | 100% |  | EE46171810 | EE46171810 | 874 | 17 |  | LEI | E | E | EE46 | 1718 | E | LND | E |  |  |  |
| EE561718 |  | CA17 ExtrBldgFl2 - Cable Pulling Details |  | 297d | 2009-12-10 A | 2011-02-14 A | EE500130, EE46171810 FF | 100% |  | EE561718 | EE561718 | 874 | 17 |  | LEI | E | E | EE56 | 1718 | E | LND | E |  |  |  |
| EE46171808 |  | CA17 ExtrStruc - Final Loads f.Civil /StrSteel |  | 46d | 2009-12-21 A | 2010-02-26 A | EE46171005 | 100% | TAE [168 h] | EE46171808 | EE46171808 | 874 | 17 |  | LEI | E | E | EE12 | 1718 | E | LND | E | 168,00 |  |  |
|  | J | **J Instrumentation** |  |  | 2008-10-06 | 2010-12-15 |  |  |  |  |  |  |  |  |  |  |  |  |  |  |  |  |  |  |  |
| EJ46171805 |  | CA17 ExtrStruc - prelimLoads f.Civil /StrSteel |  | 15d | 2008-10-06 A | 2008-10-24 A | F3060 FF | 100% |  | EJ46171805 | EJ46171805 | 86E | 17 |  | LND | E | J | EJ11 | 1718 | I | LND | E |  | 999 |  |
| EJ361718 |  | CA17 ExtrBldgFl2 - Hook-Up drwgs 1st Issue |  | 99d | 2010-02-08 A | 2010-06-30 A | A1EJ0080, F4040 FF+55d | 100% |  | EJ361718 | EJ361718 | 86E | 17 | 200 | LEI | E | J | EJ36 | 1718 | I | LND | C |  | 999 | 200 |
| EJ46171808 |  | CA17 ExtrStruc - Final Loads f.Civil /StrSteel |  | 10d | 2010-02-12 A | 2010-02-25 A | EJ46171805 | 100% |  | EJ46171808 | EJ46171808 | 86E | 17 |  | LEI | E | J | EJ12 | 1718 | I | LND | E |  | 999 |  |
| EJ46171810 |  | CA17 ExtrBldgFl2 - Instr Cable Tray Layout Pl 1st Issue |  | 150d | 2010-03-01 A | 2010-09-30 A | EE46171810 FF, F4040 FF | 100% |  | EJ46171810 | EJ46171810 | 86E | 17 |  | LEI | E | J | EJ41 | 1718 | I | LND | E |  | 999 |  |
| EJ801718 |  | CA17 ExtrBldgFl2 - Loop Diagrams |  | 79d | 2010-08-20 A | 2010-12-09 A | A1EJ0040 FF, EJ800010 | 100% |  | EJ801718 | EJ801718 | 86E | 17 |  | LEI | E | J | EJ80 | 1718 | I | LND | E |  | 999 |  |
| EJ321718 |  | CA17 ExtrBldgFl2 - JB Location drwgs |  | 67d | 2010-09-13 A | 2010-12-15 A | F4462 FF+20d, F4040 | 100% |  | EJ321718 | EJ321718 | 86E | 17 | 200 | LEI | E | J | EJ37 | 1718 | I | LND | C |  | 999 | 200 |

| ID | WBS | Activity | Type | Duration | Start | Finish | Predecessors | Complete | Resources | UDF_SAVE ACTID | UDF_SAVE ACT ID | Department | Constr. Area | PMT-Area | PMT-Phase | WBS Phase | WBS Discipline | WBS Type of Work | WBS Objects | IMS | UPT | Pro Unit/DocCode | PMT-Schedule Org | PMT-Respons. | PMT-Discipline | TB26 Ressource Budget |
| --- | --- | --- | --- | --- | --- | --- | --- | --- | --- | --- | --- | --- | --- | --- | --- | --- | --- | --- | --- | --- | --- | --- | --- | --- | --- | --- |
|  | 1720 | **1720 Extrusion Bldg 3rd Floor +117,550m (+19,05m) - CA17** |  |  | 2008-04-01 | 2011-04-11 |  |  |  |  |  |  |  |  |  |  |  |  |  |  |  |  |  |  |  |  |
|  | 0B | **0B General Activities** |  |  | 2009-01-03 | 2009-01-03 |  |  |  |  |  |  |  |  |  |  |  |  |  |  |  |  |  |  |  |  |
| E0201720 |  | CA17 ExtrBldgFl3 - freeze construction concept | milestone | 0d | 2009-01-03 A | 2009-01-03 A | AD2230 FF | 100% |  | E0201720 | E0201720 | 87A | 17 | 200 | E | E | 0B | E020 | 1720 | INS | LND |  |  |  |  |  |
|  | C | **C Civil** |  |  | 2010-06-30 | 2011-01-28 |  |  |  |  |  |  |  |  |  |  |  |  |  |  |  |  |  |  |  |  |
| EC48172010 |  | CA17 ExtrBldgFl3 - Precast/Formw/Reinf dwgs Stairtowers <24m East/South AFC |  | 53d | 2010-06-30 A | 2010-09-10 A | EC48171810 FF | 100% |  | EC48172010 | EC48172010 | 87A | 17 | 200 | E | E | C | EC48 | 1720 | PRE | LND | 1701C56 | 200 | IPR |  |  |
| EC48172020 |  | CA17 ExtrBldgFl3 - Formw/Reinf drwgs Ceiling+24m AFC |  | 80d | 2010-10-06 A | 2011-01-28 A | EC48172010 FF, EH241720 FF, EC48171820 FF+7d | 100% |  | EC48172020 | EC48172020 | 87A | 17 | 200 | E | E | C | EC48 | 1720 | ar | LND | 1701C25 | 200 | IPR |  |  |
|  | H | **H HVAC** |  |  | 2008-10-06 | 2010-10-25 |  |  |  |  |  |  |  |  |  |  |  |  |  |  |  |  |  |  |  |  |
| EH05172008 |  | CA17 ExtrBldgFl3 - prelimLoads f.Civil /StrSteel |  | 15d | 2008-10-06 A | 2008-10-24 A | F3060 FF | 100% |  | EH05172008 | EH05172008 | 87C | 17 |  | E | E | H | EH11 | 1720 | OTH | LND |  |  | LND |  |  |
| EH201720 |  | CA17 ExtrBldgFl3 - HVAC&Plumbing / Feed/Basic |  | 198d | 2008-10-06 A | 2009-07-24 A | AD2230 FF+20d | 100% |  | EH201720 | EH201720 | 87C | 17 | 200 | E | E | H | EH20 | 1720 | OTH | LND |  | 200 | LND | 035 |  |
| EH30172005 |  | CA17 ExtrBldgFl3 - HVAC Layouts Dwgs AFC |  | 217d | 2009-12-15 A | 2010-10-25 A | EH30171005 SS, EH201720 | 100% | TKB-H [480 h] | EH30172005 | EH30172005 | 87C | 17 | 200 | E | E | H | EH30 | 1720 | OTH | LND |  | 200 | IPR | 035 | 480,00 |
| EH071720 |  | CA17 ExtrBldgFl3 - Issue of Dwgs&Doc's by RDI | level of effort | 157d | 2010-03-15 A | 2010-10-25 A | EH30172005 SS+60d, EH30172005 FF | 100% | TKB-H [5120 h] | EH071720 | EH071720 | 87C | 17 | 200 | E | E | H | EH30 | 1720 | OTH | LND |  | 200 | IPR | 035 | 5120,00 |
| EH30172015 |  | CA17 ExtrBldgFl3 - Review HVAC Layout Dwgs |  | 110d | 2010-05-25 A | 2010-10-25 A | EH30172010 FF-5d | 100% | TKB-H [480 h] | EH30172015 | EH30172015 | 87C | 17 | 200 | E | E | H | EH30 | 1720 | OTH | LND |  | 200 | LND | 035 | 480,00 |
| EH30172010 |  | CA17 ExtrBldgFl3 - HVAC Layouts Dwgs IFC | milestone | 0d | 2010-07-12 A | 2010-07-12 A | EH30172005 FF-8d | 100% |  | EH30172010 | EH30172010 | 87C | 17 | 200 | E | E | H | EH30 | 1720 | OTH | LND |  | 200 | IPR | 035 |  |
| EH051720 |  | CA17 ExtrBldgFl3 - Final Loads f. StrSteel | milestone | 0d | 2010-10-14 A | 2010-10-14 A | E3H0150 SF, EH30172005 FF-8d | 100% |  | EH051720 | EH051720 | 87C | 17 | 200 |  | E | H | EH12 | 1720 | OTH | LND |  |  | IPR |  |  |
| EH241720 |  | CA17 ExtrBldgFl3 - Wall&Floor opening details | milestone | 0d | 2010-10-14 A | 2010-10-14 A | EH051720 FF, E3H0150 SF | 100% |  | EH241720 | EH241720 | 87C | 17 | 200 | E | E | H | EH24 | 1720 | OTH | LND |  | 200 | IPR | 035 |  |
|  | R | **R Piping** |  |  | 2008-04-01 | 2011-04-11 |  |  |  |  |  |  |  |  |  |  |  |  |  |  |  |  |  |  |  |  |
| ER151720 |  | CA17 ExtrBldgFl3 - Conceptual Piping |  | 169d | 2008-04-01 A | 2008-11-28 A | F2760 | 100% |  | ER151720 | ER151720 | 876 | 17 | 200 |  | E | R | ER15 | 1720 | PL | LND |  |  | LND |  |  |
| ER301720 |  | CA17 ExtrBldgFl3 - CAD Model Piping / Eqpt |  | 579d | 2008-07-01 A | 2010-10-19 A | ER391720 FF+10d, ER151720 SS, E0201720 FF | 100% |  | ER301720 | ER301720 | 876 | 17 | 200 |  | E | R | ER30 | 1720 | PL | LND |  |  | LNI |  |  |
| ER421720 |  | CA17 ExtrBldgFl3 - Stress Calculation |  | 98d | 2009-11-16 A | 2010-04-09 A | ER361720 | 100% |  | ER421720 | ER421720 | 872 | 17 | 200 |  | E | R | ER42 | 1720 | PL | LND |  |  | LND |  |  |
| ER361720 |  | CA17 ExtrBldgFl3 - CAD Model Review 60% |  | 15d | 2010-03-01 A | 2010-03-19 A | F4040 FF | 100% |  | ER361720 | ER361720 | 876 | 17 | 200 |  | E | R | ER36 | 1720 | 2 | LND |  |  | LND |  |  |
| ER391720 |  | CA17 ExtrBldgFl3 - CAD Model Review 90% |  | 10d | 2010-09-06 A | 2010-09-17 A | F4462 FF | 100% |  | ER391720 | ER391720 | 876 | 17 | 200 |  | E | R | ER39 | 1720 | 3 | LND |  |  | LND |  |  |
| ER451720 |  | CA17 ExtrBldgFl3 - Piping Isometrics |  | 59d | 2010-09-27 A | 2010-12-17 A | ER421720, ER301720 FF+10d, ER391720 FS+5d | 100% |  | ER451720 | ER451720 | 876 | 17 | 200 |  | E | R | ER45 | 1720 | 5 | LND |  |  | LEI |  |  |
| ER45172005 |  | CA17 ExtrBldgFl3 - Piping Isometrics (ZEP) |  | 59d | 2010-09-27 A | 2010-12-17 A | ER301720 FF+10d, ER421720, ER391720 FS+5d | 100% |  | ER45172005 | ER45172005 | 876 | 17 | 200 |  | E | R | ER45 | 1720 | 5 | LND |  |  | ZEP |  |  |
| ER49172005 |  | CA17 ExtrBldgFl3 - Design Check/Rel.Isos&BOM ZEP |  | 94d | 2010-10-15 A | 2011-02-28 A | ER451720 SS+10d, ER45172005 SS+10d | 100% |  | ER49172005 | ER49172005 | 876 | 17 | 200 |  | E | R | ER49 | 1720 | 5 | LND |  |  | ZEP |  |  |
| ER491720 |  | CA17 ExtrBldgFl3 - Design Check/ Rel.Isos&BOM |  | 107d | 2010-11-09 A | 2011-04-11 A | ER451720 FF+20d, ER45172005 FF+20d, IMS-E-000110 FF | 100% |  | ER491720 | ER491720 | 876 | 17 | 200 |  | E | R | ER49 | 1720 | 5 | LND |  |  | LEI |  |  |

| ID | WBS | Activity | Type | Duration | Start | Finish | Predecessors | Complete | Resources | UDF_SAVE ACTID | UDF_SAVE ACT ID | Department | Constr. Area | PMT-Phase | PMT-Respons. | WBS Phase | WBS Discipline | WBS Type of Work | WBS Objects | IMS | UPT | Pro Unit/DocCode | PMT-Area | PMT-Schedule Org | UDF_CONTRACT START DATE | UDF_CONTRACT FINISH DATE | UDF_CONTRACT ITEM | PMT-Discipline | TB26 Ressource Budget |
| --- | --- | --- | --- | --- | --- | --- | --- | --- | --- | --- | --- | --- | --- | --- | --- | --- | --- | --- | --- | --- | --- | --- | --- | --- | --- | --- | --- | --- | --- |
|  | E | **E Electrical** |  |  | 2009-04-06 | 2011-02-14 |  |  |  |  |  |  |  |  |  |  |  |  |  |  |  |  |  |  |  |  |  |  |  |
| EE901720 |  | CA17 ExtrBldgFl3 - Earthing Details |  | 30d | 2009-04-06 A | 2009-05-20 A | EE901710 SS | 100% |  | EE901720 | EE901720 | 874 | 17 | E | LND | E | E | EE90 | 1720 | E | LND |  |  |  |  |  |  |  |  |
| EE46172010 |  | CA17 ExtrBldgFl3 - El. CableTray Layout Pl. / LOP's 1st Issue |  | 217d | 2009-12-07 A | 2010-10-15 A | EE460000, F4040 FF+25d | 100% |  | EE46172010 | EE46172010 | 874 | 17 | E | LEI | E | E | EE46 | 1720 | E | LND |  |  |  |  |  |  |  |  |
| EE561720 |  | CA17 ExtrBldgFl3 - Cable Pulling Details |  | 297d | 2009-12-10 A | 2011-02-14 A | EE500130, EE46172010 FF | 100% |  | EE561720 | EE561720 | 874 | 17 | E | LEI | E | E | EE56 | 1720 | E | LND |  |  |  |  |  |  |  |  |
|  | J | **J Instrumentation** |  |  | 2010-02-08 | 2010-12-15 |  |  |  |  |  |  |  |  |  |  |  |  |  |  |  |  |  |  |  |  |  |  |  |
| EJ361720 |  | CA17 ExtrBldgFl3 - Hook-Up drwgs 1st Issue |  | 99d | 2010-02-08 A | 2010-06-30 A | F4040 FF+55d, A1EJ0080 | 100% |  | EJ361720 | EJ361720 | 86E | 17 | C | LEI | E | J | EJ36 | 1720 | I | LND | 999 | 200 | 200 |  |  |  |  |  |
| EJ46172010 |  | CA17 ExtrBldgFl3 - Instr Cable Tray Layout Pl 1st Issue |  | 150d | 2010-03-01 A | 2010-09-30 A | EE46172010 FF, F4040 FF | 100% |  | EJ46172010 | EJ46172010 | 86E | 17 | E | LEI | E | J | EJ41 | 1720 | I | LND | 999 |  |  | 2011-06-10 | 2011-11-30 | E-15-01-11 |  |  |
| EJ801720 |  | CA17 ExtrBldgFl3 - Loop Diagrams |  | 79d | 2010-08-20 A | 2010-12-09 A | A1EJ0040 FF, EJ800010 | 100% |  | EJ801720 | EJ801720 | 86E | 17 | E | LEI | E | J | EJ80 | 1720 | I | LND | 999 |  |  |  |  |  |  |  |
| EJ321720 |  | CA17 ExtrBldgFl3 - JB Location drwgs |  | 67d | 2010-09-13 A | 2010-12-15 A | F4462 FF+20d, F4040 | 100% |  | EJ321720 | EJ321720 | 86E | 17 | C | LEI | E | J | EJ37 | 1720 | I | LND | 999 | 200 | 200 |  |  |  |  |  |
|  | 1730 | **1730 Extrusion Bldg 4th Floor +123,850m (+25,35m) - CA17** |  |  | 2008-04-01 | 2011-04-11 |  |  |  |  |  |  |  |  |  |  |  |  |  |  |  |  |  |  |  |  |  |  |  |
|  | 0B | **0B General Activities** |  |  | 2009-01-03 | 2009-01-03 |  |  |  |  |  |  |  |  |  |  |  |  |  |  |  |  |  |  |  |  |  |  |  |
| E0201730 |  | CA17 ExtrBldgFl4 - freeze construction concept | milestone | 0d | 2009-01-03 A | 2009-01-03 A | AD2230 FF | 100% |  | E0201730 | E0201730 | 87A | 17 | E |  | E | 0B | E020 | 1730 | INS | LND |  | 200 |  |  |  |  |  |  |
|  | C | **C Civil** |  |  | 2010-07-07 | 2011-01-28 |  |  |  |  |  |  |  |  |  |  |  |  |  |  |  |  |  |  |  |  |  |  |  |
| EC48173010 |  | CA17 ExtrBldgFl4 - Precast/Formw/Reinf dwgs Stairtowers <30m East/South AFC |  | 48d | 2010-07-07 A | 2010-09-10 A | EC48172010 FF, IMS-E-000140 FF, HEC48P FF | 100% |  | EC48173010 | EC48173010 | 87A | 17 | E | IPR | E | C | EC48 | 1730 | PRE | LND | 1701C57 | 200 | 200 |  |  |  |  |  |
| EC48173020 |  | CA17 ExtrBldgFl4 - Formw/Reinf drwgs Ceiling+30m AFC |  | 62d | 2010-11-01 A | 2011-01-28 A | EC48172020 FF, EC48173010 FF, EH241730 FF | 100% |  | EC48173020 | EC48173020 | 87A | 17 | E | IPR | E | C | EC48 | 1730 | ar | LND | 1701C26 | 200 | 200 |  |  |  |  |  |
|  | H | **H HVAC** |  |  | 2008-10-06 | 2010-10-25 |  |  |  |  |  |  |  |  |  |  |  |  |  |  |  |  |  |  |  |  |  |  |  |
| EH05173008 |  | CA17 ExtrBldgFl4 - prelimLoads f.Civil /StrSteel |  | 15d | 2008-10-06 A | 2008-10-24 A | F3060 FF | 100% |  | EH05173008 | EH05173008 | 87C | 17 | E | LND | E | H | EH11 | 1730 | OTH | LND |  |  |  |  |  |  |  |  |
| EH201730 |  | CA17 ExtrBldgFl4 - HVAC&Plumbing / Feed/Basic |  | 198d | 2008-10-06 A | 2009-07-24 A | AD2230 FF+20d | 100% |  | EH201730 | EH201730 | 87C | 17 | E | LND | E | H | EH20 | 1730 | OTH | LND |  | 200 | 200 |  |  |  | 035 |  |
| EH30173005 |  | CA17 ExtrBldgFl4 - HVAC Layouts Dwgs AFC |  | 217d | 2009-12-15 A | 2010-10-25 A | EH30171005 SS, EH201730 | 100% | TKB-H [480 h] | EH30173005 | EH30173005 | 87C | 17 | E | IPR | E | H | EH30 | 1730 | OTH | LND |  | 200 | 200 |  |  |  | 035 | 480,00 |
| EH071730 |  | CA17 ExtrBldgFl4 - Issue of Dwgs&Doc's by RDI | level of effort | 157d | 2010-03-15 A | 2010-10-25 A | EH30173005 FF, EH30173005 SS+60d | 100% | TKB-H [5120 h] | EH071730 | EH071730 | 87C | 17 | E | IPR | E | H | EH30 | 1730 | OTH | LND |  | 200 | 200 |  |  |  | 035 | 5120,00 |
| EH30173015 |  | CA17 ExtrBldgFl4 - Review HVAC Layout Dwgs |  | 110d | 2010-05-25 A | 2010-10-25 A | EH30173010 FF-5d | 100% | TKB-H [480 h] | EH30173015 | EH30173015 | 87C | 17 | E | LND | E | H | EH30 | 1730 | OTH | LND |  | 200 | 200 |  |  |  | 035 | 480,00 |
| EH30173010 |  | CA17 ExtrBldgFl4 - HVAC Layouts Dwgs IFC | milestone | 0d | 2010-07-12 A | 2010-07-12 A | EH30173005 FF-8d | 100% |  | EH30173010 | EH30173010 | 87C | 17 | E | IPR | E | H | EH30 | 1730 | OTH | LND |  | 200 | 200 |  |  |  | 035 |  |
| EH051730 |  | CA17 ExtrBldgFl4 - Final Loads f. StrSteel | milestone | 0d | 2010-10-14 A | 2010-10-14 A | EH30173005 FF-8d, E3H0150 SF | 100% |  | EH051730 | EH051730 | 87C | 17 |  | IPR | E | H | EH12 | 1730 | OTH | LND |  | 200 |  |  |  |  |  |  |
| EH241730 |  | CA17 ExtrBldgFl4 - Wall&Floor opening details | milestone | 0d | 2010-10-14 A | 2010-10-14 A | EH051730 FF, E3H0150 SF | 100% |  | EH241730 | EH241730 | 87C | 17 | E | IPR | E | H | EH24 | 1730 | OTH | LND |  | 200 | 200 |  |  |  | 035 |  |

| ID | WBS | Activity | Type | Duration | Start | Finish | Predecessors | Complete | UDF_SAVE ACTID | UDF_SAVE ACT ID | Department | Constr. Area | PMT-Area | PMT-Respons. | WBS Phase | WBS Discipline | WBS Type of Work | WBS Objects | IMS | UPT | UDF_Actictity Name (Russia) | Zeigen/n. Zeigen | PMT-Phase | Pro Unit/DocCode | PMT-Schedule Org | UDF_CONTRACT START DATE | UDF_CONTRACT FINISH DATE | UDF_CONTRACT ITEM |
| --- | --- | --- | --- | --- | --- | --- | --- | --- | --- | --- | --- | --- | --- | --- | --- | --- | --- | --- | --- | --- | --- | --- | --- | --- | --- | --- | --- | --- |
|  | R | **R Piping** |  |  | 2008-04-01 | 2011-04-11 |  |  |  |  |  |  |  |  |  |  |  |  |  |  |  |  |  |  |  |  |  |  |
| ER151730 |  | CA17 ExtrBldgFl4 - Conceptual Piping |  | 169d | 2008-04-01 A | 2008-11-28 A | F2760 | 100% | ER151730 | ER151730 | 876 | 17 | 200 | LND | E | R | ER15 | 1730 | PL | LND |  |  |  |  |  |  |  |  |
| HER30 |  | CAD Model Piping / Equipment | level of effort | 620d | 2008-05-02 A | 2010-10-19 A | ER305101 SS, ER305102 SS, ER305103 SS, ER305104 SS | 100% | HER30 | HER30 | 873 | 17 | 200 | LNI | E | R | ER00 | 1730 | 1 | LND | Модель CAD, трубопроводы / оборудование | L2 |  |  |  |  |  |  |
| ER301730 |  | CA17 ExtrBldgFl4 - CAD Model Piping / Eqpt |  | 579d | 2008-07-01 A | 2010-10-19 A | ER391730 FF+10d, ER151730 SS, E0201730 FF | 100% | ER301730 | ER301730 | 876 | 17 | 200 | LNI | E | R | ER30 | 1730 | PL | LND |  |  |  |  |  |  |  |  |
| ER421730 |  | CA17 ExtrBldgFl4 - Stress Calculation |  | 98d | 2009-11-16 A | 2010-04-09 A | ER361730 | 100% | ER421730 | ER421730 | 872 | 17 | 200 | LND | E | R | ER42 | 1730 | PL | LND |  |  |  |  |  |  |  |  |
| ER361730 |  | CA17 ExtrBldgFl4 - CAD Model Review 60% |  | 15d | 2010-03-01 A | 2010-03-19 A | F4040 FF | 100% | ER361730 | ER361730 | 876 | 17 | 200 | LND | E | R | ER36 | 1730 | 2 | LND |  |  |  |  |  |  |  |  |
| ER391730 |  | CA17 ExtrBldgFl4 - CAD Model Review 90% |  | 10d | 2010-09-06 A | 2010-09-17 A | F4462 FF | 100% | ER391730 | ER391730 | 876 | 17 | 200 | LND | E | R | ER39 | 1730 | 3 | LND |  |  |  |  |  |  |  |  |
| ER451730 |  | CA17 ExtrBldgFl4 - Piping Isometrics |  | 59d | 2010-09-27 A | 2010-12-17 A | ER421730, ER301730 FF+10d, ER391730 FS+5d | 100% | ER451730 | ER451730 | 876 | 17 | 200 | LEI | E | R | ER45 | 1730 | 5 | LND |  |  |  |  |  |  |  |  |
| ER45173005 |  | CA17 ExtrBldgFl4 - Piping Isometrics (ZEP) |  | 59d | 2010-09-27 A | 2010-12-17 A | ER391730 FS+5d, ER301730 FF+10d, ER421730 | 100% | ER45173005 | ER45173005 | 876 | 17 | 200 | ZEP | E | R | ER45 | 1730 | 5 | LND |  |  |  |  |  |  |  |  |
| ER49173005 |  | CA17 ExtrBldgFl4 - Design Check/Rel.Isos&BOM ZEP |  | 94d | 2010-10-15 A | 2011-02-28 A | ER451730 SS+10d, ER45173005 SS+10d | 100% | ER49173005 | ER49173005 | 876 | 17 | 200 | ZEP | E | R | ER49 | 1730 | 5 | LND |  |  |  |  |  |  |  |  |
| ER491730 |  | CA17 ExtrBldgFl4 - Design Check/ Rel.Isos&BOM |  | 107d | 2010-11-09 A | 2011-04-11 A | IMS-E-000110 FF, ER451730 FF+20d, ER45173005 FF+20d | 100% | ER491730 | ER491730 | 876 | 17 | 200 | LEI | E | R | ER49 | 1730 | 5 | LND |  |  |  |  |  |  |  |  |
|  | E | **E Electrical** |  |  | 2009-04-06 | 2011-02-14 |  |  |  |  |  |  |  |  |  |  |  |  |  |  |  |  |  |  |  |  |  |  |
| EE901730 |  | CA17 ExtrBldgFl4 - Earthing Details |  | 30d | 2009-04-06 A | 2009-05-20 A | EE901710 SS | 100% | EE901730 | EE901730 | 874 | 17 |  | LND | E | E | EE90 | 1730 | E | LND |  |  | E |  |  |  |  |  |
| EE46173010 |  | CA17 ExtrBldgFl4 - El. CableTray Layout Pl. / LOP's 1st Issue |  | 227d | 2009-12-07 A | 2010-10-29 A | EE460000, F4040 FF+25d | 100% | EE46173010 | EE46173010 | 874 | 17 |  | LEI | E | E | EE46 | 1730 | E | LND |  |  | E |  |  |  |  |  |
| EE561730 |  | CA17 ExtrBldgFl4 - Cable Pulling Details |  | 297d | 2009-12-10 A | 2011-02-14 A | EE46173010 FF, EE500130 | 100% | EE561730 | EE561730 | 874 | 17 |  | LEI | E | E | EE56 | 1730 | E | LND |  |  | E |  |  |  |  |  |
|  | J | **J Instrumentation** |  |  | 2010-02-08 | 2010-12-15 |  |  |  |  |  |  |  |  |  |  |  |  |  |  |  |  |  |  |  |  |  |  |
| EJ361730 |  | CA17 ExtrBldgFl4 - Hook-Up drwgs 1st Issue |  | 99d | 2010-02-08 A | 2010-06-30 A | F4040 FF+55d, A1EJ0080 | 100% | EJ361730 | EJ361730 | 86E | 17 | 200 | LEI | E | J | EJ36 | 1730 | I | LND |  |  | C | 999 | 200 |  |  |  |
| EJ46173010 |  | CA17 ExtrBldgFl4 - Instr CableTray Layout Pl. 1st Issue |  | 150d | 2010-03-01 A | 2010-09-30 A | F4040 FF, EE46173010 FF | 100% | EJ46173010 | EJ46173010 | 86E | 17 |  | LEI | E | J | EJ41 | 1730 | I | LND |  |  | E | 999 |  | 2011-06-10 | 2011-11-30 | E-15-01-11 |
| EJ801730 |  | CA17 ExtrBldgFl4 - Loop Diagrams |  | 79d | 2010-08-20 A | 2010-12-09 A | A1EJ0040 FF, EJ800010 | 100% | EJ801730 | EJ801730 | 86E | 17 |  | LEI | E | J | EJ80 | 1730 | I | LND |  |  | E | 999 |  |  |  |  |
| EJ321730 |  | CA17 ExtrBldgFl4 - JB Location drwgs |  | 67d | 2010-09-13 A | 2010-12-15 A | F4462 FF+20d, F4040 | 100% | EJ321730 | EJ321730 | 86E | 17 | 200 | LEI | E | J | EJ37 | 1730 | I | LND |  |  | C | 999 | 200 |  |  |  |
|  | 1736 | **1736 Extrusion Bldg 5th Floor +130,150m (+31,65m) - CA17** |  |  | 2008-04-01 | 2011-04-11 |  |  |  |  |  |  |  |  |  |  |  |  |  |  |  |  |  |  |  |  |  |  |
|  | 0B | **0B General Activities** |  |  | 2009-01-03 | 2009-01-03 |  |  |  |  |  |  |  |  |  |  |  |  |  |  |  |  |  |  |  |  |  |  |
| E0201736 |  | CA17 ExtrBldgFl5 - freeze construction concept | milestone | 0d | 2009-01-03 A | 2009-01-03 A | AD2230 FF | 100% | E0201736 | E0201736 | 87A | 17 | 200 |  | E | 0B | E020 | 1736 | INS | LND |  |  | E |  |  |  |  |  |
|  | C | **C Civil** |  |  | 2010-07-14 | 2011-03-28 |  |  |  |  |  |  |  |  |  |  |  |  |  |  |  |  |  |  |  |  |  |  |
| EC48173610 |  | CA17 ExtrBldgFl5 - Precast/Formw/Reinf dwgs Stairtowers <36m East/South AFC |  | 43d | 2010-07-14 A | 2010-09-10 A | HEC48S FF, EC48173010 FF, HEC48P FF, IMS-E-000140 FF | 100% | EC48173610 | EC48173610 | 87A | 17 | 200 | IPR | E | C | EC48 | 1736 | PRE | LND |  |  | E | 1701C58 | 200 |  |  |  |
| EC48173620 |  | CA17 ExtrBldgFl5 - Formw/Reinf drwgs Roof+36m AFC |  | 103d | 2010-11-01 A | 2011-03-28 A | HEC48S FF, EC48173610 FF, EC48173020 FF, EH241736 FF | 100% | EC48173620 | EC48173620 | 87A | 17 | 200 | IPR | E | C | EC48 | 1736 | ar | LND |  |  | E | 1701C27 | 200 |  |  |  |

| ID | WBS | Activity | Type | Duration | Start | Finish | Predecessors | Complete | Resources | UDF_SAVE ACTID | UDF_SAVE ACT ID | Department | Constr. Area | PMT-Phase | PMT-Respons. | WBS Phase | WBS Discipline | WBS Type of Work | WBS Objects | IMS | UPT | PMT-Area | PMT-Schedule Org | PMT-Discipline | TB26 Ressource Budget | Pro Unit/DocCode |
| --- | --- | --- | --- | --- | --- | --- | --- | --- | --- | --- | --- | --- | --- | --- | --- | --- | --- | --- | --- | --- | --- | --- | --- | --- | --- | --- |
|  | H | **H HVAC** |  |  | 2008-10-06 | 2010-12-30 |  |  |  |  |  |  |  |  |  |  |  |  |  |  |  |  |  |  |  |  |
| EH05173608 |  | CA17 ExtrBldgFl5 - prelimLoads f.Civil /StrSteel |  | 15d | 2008-10-06 A | 2008-10-24 A | F3060 FF | 100% |  | EH05173608 | EH05173608 | 87C | 17 | E | LND | E | H | EH11 | 1736 | OTH | LND |  |  |  |  |  |
| EH201736 |  | CA17 ExtrBldgFl5 - HVAC&Plumbing / Feed/Basic |  | 198d | 2008-10-06 A | 2009-07-24 A | AD2230 FF+20d | 100% |  | EH201736 | EH201736 | 87C | 17 | E | LND | E | H | EH20 | 1736 | OTH | LND | 200 | 200 | 035 |  |  |
| EH30173605 |  | CA17 ExtrBldgFl5 - HVAC Layouts Dwgs AFC |  | 236d | 2009-12-15 A | 2010-11-22 A | EH30171005 SS, EH201736 | 100% | TKB-H [480 h] | EH30173605 | EH30173605 | 87C | 17 | E | IPR | E | H | EH30 | 1736 | OTH | LND | 200 | 200 | 035 | 480,00 |  |
| EH071736 |  | CA17 ExtrBldgFl5 - Issue of Dwgs&Doc's by RDI | level of effort | 176d | 2010-03-15 A | 2010-11-22 A | EH30173605 SS+60d, EH30173605 FF | 100% | TKB-H [5120 h] | EH071736 | EH071736 | 87C | 17 | E | IPR | E | H | EH30 | 1736 | OTH | LND | 200 | 200 | 035 | 5120,00 |  |
| EH30173615 |  | CA17 ExtrBldgFl5 - Review HVAC Layout Dwgs |  | 156d | 2010-05-25 A | 2010-12-30 A | EH30173610 FF-5d | 100% | TKB-H [480 h] | EH30173615 | EH30173615 | 87C | 17 | E | LND | E | H | EH30 | 1736 | OTH | LND | 200 | 200 | 035 | 480,00 |  |
| EH30173610 |  | CA17 ExtrBldgFl5 - HVAC Layouts Dwgs IFC | milestone | 0d | 2010-07-12 A | 2010-07-12 A | EH30173605 FF-8d | 100% |  | EH30173610 | EH30173610 | 87C | 17 | E | IPR | E | H | EH30 | 1736 | OTH | LND | 200 | 200 | 035 |  |  |
| EH051736 |  | CA17 ExtrBldgFl5 - Final Loads f. StrSteel | milestone | 0d | 2010-11-10 A | 2010-11-10 A | EH30173605 FF-8d, E3H0150 SF | 100% |  | EH051736 | EH051736 | 87C | 17 |  | IPR | E | H | EH12 | 1736 | OTH | LND | 200 |  |  |  |  |
| EH241736 |  | CA17 ExtrBldgFl5 - Wall&Floor opening details | milestone | 0d | 2010-11-10 A | 2010-11-10 A | E3H0150 SF, EH051736 FF | 100% |  | EH241736 | EH241736 | 87C | 17 | E | IPR | E | H | EH24 | 1736 | OTH | LND | 200 | 200 | 035 |  |  |
|  | R | **R Piping** |  |  | 2008-04-01 | 2011-04-11 |  |  |  |  |  |  |  |  |  |  |  |  |  |  |  |  |  |  |  |  |
| ER151736 |  | CA17 ExtrBldgFl5 - Conceptual Piping |  | 169d | 2008-04-01 A | 2008-11-28 A | F2760 | 100% |  | ER151736 | ER151736 | 876 | 17 |  | LND | E | R | ER15 | 1736 | PL | LND | 200 |  |  |  |  |
| ER301736 |  | CA17 ExtrBldgFl5 - CAD Model Piping / Eqpt |  | 579d | 2008-07-01 A | 2010-10-19 A | ER151736 SS, ER391736 FF+10d, E0201736 FF | 100% |  | ER301736 | ER301736 | 876 | 17 |  | LNI | E | R | ER30 | 1736 | PL | LND | 200 |  |  |  |  |
| ER421736 |  | CA17 ExtrBldgFl5 - Stress Calculation |  | 98d | 2009-11-16 A | 2010-04-09 A | ER361736 | 100% |  | ER421736 | ER421736 | 872 | 17 |  | LND | E | R | ER42 | 1736 | PL | LND | 200 |  |  |  |  |
| ER361736 |  | CA17 ExtrBldgFl5 - CAD Model Review 60% |  | 15d | 2010-03-01 A | 2010-03-19 A | F4040 FF | 100% |  | ER361736 | ER361736 | 876 | 17 |  | LND | E | R | ER36 | 1736 | 2 | LND | 200 |  |  |  |  |
| ER391736 |  | CA17 ExtrBldgFl5 - CAD Model Review 90% |  | 10d | 2010-09-06 A | 2010-09-17 A | F4462 FF | 100% |  | ER391736 | ER391736 | 876 | 17 |  | LND | E | R | ER39 | 1736 | 3 | LND | 200 |  |  |  |  |
| ER451736 |  | CA17 ExtrBldgFl5 - Piping Isometrics |  | 59d | 2010-09-27 A | 2010-12-17 A | ER391736 FS+5d, ER301736 FF+10d, ER421736 | 100% |  | ER451736 | ER451736 | 876 | 17 |  | LEI | E | R | ER45 | 1736 | 5 | LND | 200 |  |  |  |  |
| ER45173605 |  | CA17 ExtrBldgFl5 - Piping Isometrics (ZEP) |  | 59d | 2010-09-27 A | 2010-12-17 A | ER421736, ER301736 FF+10d, ER45176005 SS, ER391736 FS+5d | 100% |  | ER45173605 | ER45173605 | 876 | 17 |  | ZEP | E | R | ER45 | 1736 | 5 | LND | 200 |  |  |  |  |
| ER49173605 |  | CA17 ExtrBldgFl5 - Design Check/Rel.Isos&BOM ZEP |  | 94d | 2010-10-15 A | 2011-02-28 A | ER451736 SS+10d, ER45173605 SF+10d | 100% |  | ER49173605 | ER49173605 | 876 | 17 |  | ZEP | E | R | ER49 | 1736 | 5 | LND | 200 |  |  |  |  |
| ER491736 |  | CA17 ExtrBldgFl5 - Design Check/ Rel.Isos&BOM |  | 107d | 2010-11-09 A | 2011-04-11 A | ER45173605 FF+20d, ER451736 FF+20d, IMS-E-000110 FF | 100% |  | ER491736 | ER491736 | 876 | 17 |  | LEI | E | R | ER49 | 1736 | 5 | LND | 200 |  |  |  |  |
|  | E | **E Electrical** |  |  | 2009-04-06 | 2011-02-14 |  |  |  |  |  |  |  |  |  |  |  |  |  |  |  |  |  |  |  |  |
| EE901736 |  | CA17 ExtrBldgFl5 - Earthing Details |  | 30d | 2009-04-06 A | 2009-05-20 A | EE901710 SS | 100% |  | EE901736 | EE901736 | 874 | 17 | E | LND | E | E | EE90 | 1736 | E | LND |  |  |  |  |  |
| EE46173610 |  | CA17 ExtrBldgFl5 - El. CableTray Layout Pl. / LOP's 1st Issue |  | 227d | 2009-12-07 A | 2010-10-29 A | EE460000, F4040 FF+25d | 100% |  | EE46173610 | EE46173610 | 874 | 17 | E | LEI | E | E | EE46 | 1736 | E | LND |  |  |  |  |  |
| EE561736 |  | CA17 ExtrBldgFl5 - Cable Pulling Details |  | 297d | 2009-12-10 A | 2011-02-14 A | EE46173610 FF, EE500130 | 100% |  | EE561736 | EE561736 | 874 | 17 | E | LEI | E | E | EE56 | 1736 | E | LND |  |  |  |  |  |
|  | J | **J Instrumentation** |  |  | 2010-02-08 | 2010-12-15 |  |  |  |  |  |  |  |  |  |  |  |  |  |  |  |  |  |  |  |  |
| EJ361736 |  | CA17 ExtrBldgFl5 - Hook-Up drwgs 1st Issue |  | 99d | 2010-02-08 A | 2010-06-30 A | F4040 FF+55d, A1EJ0080 | 100% |  | EJ361736 | EJ361736 | 86E | 17 | C | LEI | E | J | EJ36 | 1736 | I | LND | 200 | 200 |  |  | 999 |
| EJ46173610 |  | CA17 ExtrBldgFl5 - Instr CableTray Layout Pl. 1st Issue |  | 150d | 2010-03-01 A | 2010-09-30 A | EE46173610 FF, F4040 FF | 100% |  | EJ46173610 | EJ46173610 | 86E | 17 | E | LEI | E | J | EJ41 | 1736 | I | LND |  |  |  |  | 999 |
| EJ801736 |  | CA17 ExtrBldgFl5 - Loop Diagrams |  | 79d | 2010-08-20 A | 2010-12-09 A | EJ800010, A1EJ0040 FF | 100% |  | EJ801736 | EJ801736 | 86E | 17 | E | LEI | E | J | EJ80 | 1736 | I | LND |  |  |  |  | 999 |
| EJ321736 |  | CA17 ExtrBldgFl5 - JB Location drwgs |  | 67d | 2010-09-13 A | 2010-12-15 A | F4462 FF+20d, F4040 | 100% |  | EJ321736 | EJ321736 | 86E | 17 | C | LEI | E | J | EJ37 | 1736 | I | LND | 200 | 200 |  |  | 999 |

| ID | WBS | Activity | Type | Duration | Start | Finish | Predecessors | Complete | Resources | UDF_SAVE ACTID | UDF_SAVE ACT ID | Department | Constr. Area | PMT-Area | PMT-Phase | WBS Phase | WBS Discipline | WBS Type of Work | WBS Objects | IMS | UPT | Pro Unit/DocCode | PMT-Schedule Org | PMT-Respons. | PMT-Discipline | TB26 Ressource Budget | Zeigen/n. Zeigen |
| --- | --- | --- | --- | --- | --- | --- | --- | --- | --- | --- | --- | --- | --- | --- | --- | --- | --- | --- | --- | --- | --- | --- | --- | --- | --- | --- | --- |
|  | 1740 | **1740 Extrusion Bldg 6th Floor +136,450m (+37,95m) - CA17** |  |  | 2008-04-01 | 2011-04-11 |  |  |  |  |  |  |  |  |  |  |  |  |  |  |  |  |  |  |  |  |  |
|  | 0B | **0B General Activities** |  |  | 2009-01-03 | 2009-01-03 |  |  |  |  |  |  |  |  |  |  |  |  |  |  |  |  |  |  |  |  |  |
| E0201740 |  | CA17 ExtrBldgFl6 - freeze construction concept | milestone | 0d | 2009-01-03 A | 2009-01-03 A | AD2230 FF | 100% |  | E0201740 | E0201740 | 87A | 17 | 200 | E | E | 0B | E020 | 1740 | INS | LND |  |  |  |  |  |  |
|  | C | **C Civil** |  |  | 2010-11-01 | 2011-03-28 |  |  |  |  |  |  |  |  |  |  |  |  |  |  |  |  |  |  |  |  |  |
| EC48174010 |  | CA17 ExtrBldgFl6 - Formw/Reinf drwgs abv 36m AFC |  | 103d | 2010-11-01 A | 2011-03-28 A | IMS-E-000120 FF, HEC48S FF, EC120 FF, EH241740 FF, EC48173620 FF | 100% |  | EC48174010 | EC48174010 | 87A | 17 | 200 | E | E | C | EC48 | 1740 | ar | LND | 1701C28 | 200 | IPR |  |  |  |
|  | H | **H HVAC** |  |  | 2008-10-06 | 2010-12-30 |  |  |  |  |  |  |  |  |  |  |  |  |  |  |  |  |  |  |  |  |  |
| EH05174008 |  | CA17 ExtrBldgFl6 - prelimLoads f.Civil /StrSteel |  | 15d | 2008-10-06 A | 2008-10-24 A | F3060 FF | 100% |  | EH05174008 | EH05174008 | 87C | 17 |  | E | E | H | EH11 | 1740 | OTH | LND |  |  | LND |  |  |  |
| EH201740 |  | CA17 ExtrBldgFl6 - HVAC&Plumbing / Feed/Basic |  | 198d | 2008-10-06 A | 2009-07-24 A | AD2230 FF+20d | 100% |  | EH201740 | EH201740 | 87C | 17 | 200 | E | E | H | EH20 | 1740 | OTH | LND |  | 200 | LND | 035 |  |  |
| EH30174005 |  | CA17 ExtrBldgFl6 - HVAC Layouts Dwgs AFC |  | 236d | 2009-12-15 A | 2010-11-22 A | EH30171005 SS, EH201740 | 100% | TKB-H [480 h] | EH30174005 | EH30174005 | 87C | 17 | 200 | E | E | H | EH30 | 1740 | OTH | LND |  | 200 | IPR | 035 | 480,00 |  |
| EH071740 |  | CA17 ExtrBldgFl6 - Issue of Dwgs&Doc's by RDI | level of effort | 176d | 2010-03-15 A | 2010-11-22 A | EH30174005 SS+60d, EH30174005 FF | 100% | TKB-H [4984 h] | EH071740 | EH071740 | 87C | 17 | 200 | E | E | H | EH30 | 1740 | OTH | LND |  | 200 | IPR | 035 | 4984,00 |  |
| EH30174015 |  | CA17 ExtrBldgFl6 - Review HVAC Layout Dwgs |  | 156d | 2010-05-25 A | 2010-12-30 A | EH30174010 FF-5d | 100% | TKB-H [480 h] | EH30174015 | EH30174015 | 87C | 17 | 200 | E | E | H | EH30 | 1740 | OTH | LND |  | 200 | LND | 035 | 480,00 |  |
| EH30174010 |  | CA17 ExtrBldgFl6 - HVAC Layouts Dwgs IFC | milestone | 0d | 2010-07-12 A | 2010-07-12 A | EH30174005 FF-8d | 100% |  | EH30174010 | EH30174010 | 87C | 17 | 200 | E | E | H | EH30 | 1740 | OTH | LND |  | 200 | IPR | 035 |  |  |
| EH051740 |  | CA17 ExtrBldgFl6 - Final Loads f. StrSteel | milestone | 0d | 2010-11-10 A | 2010-11-10 A | E3H0150 SF, EH30174005 FF-8d | 100% |  | EH051740 | EH051740 | 87C | 17 | 200 |  | E | H | EH12 | 1740 | OTH | LND |  |  | IPR |  |  |  |
| EH241740 |  | CA17 ExtrBldgFl6 - Wall&Floor opening details | milestone | 0d | 2010-11-10 A | 2010-11-10 A | EH051740 FF, E3H0150 SF, HEH24 FF | 100% |  | EH241740 | EH241740 | 87C | 17 | 200 | E | E | H | EH24 | 1740 | OTH | LND |  | 200 | IPR | 035 |  |  |
|  | R | **R Piping** |  |  | 2008-04-01 | 2011-04-11 |  |  |  |  |  |  |  |  |  |  |  |  |  |  |  |  |  |  |  |  |  |
| ER151740 |  | CA17 ExtrBldgFl6 - Conceptual Piping |  | 169d | 2008-04-01 A | 2008-11-28 A | F2760 | 100% |  | ER151740 | ER151740 | 876 | 17 | 200 |  | E | R | ER15 | 1740 | PL | LND |  |  | LND |  |  |  |
| ER301740 |  | CA17 ExtrBldgFl6 - CAD Model Piping / Eqpt |  | 579d | 2008-07-01 A | 2010-10-19 A | ER151740 SS, E0201740 FF, ER391740 FF+10d | 100% |  | ER301740 | ER301740 | 876 | 17 | 200 |  | E | R | ER30 | 1740 | PL | LND |  |  | LNI |  |  |  |
| HER20 |  | Piping Mat. - Technical Eval's/PO Specs | level of effort | 421d | 2009-04-15 A | 2010-12-13 A | E3R0120 SS, E3R0620 SS, E3R06B20 SS, E3R0220 SS, E3R06A20 SS | 100% |  | HER20 | HER20 | 873 | 17 | 200 |  | E | R | ER00 | 1740 | PI | LND |  |  | LND |  |  | L2 |
| ER421740 |  | CA17 ExtrBldgFl6 - Stress Calculation |  | 98d | 2009-11-16 A | 2010-04-09 A | ER361740 | 100% |  | ER421740 | ER421740 | 872 | 17 | 200 |  | E | R | ER42 | 1740 | PL | LND |  |  | LND |  |  |  |
| ER361740 |  | CA17 ExtrBldgFl6 - CAD Model Review 60% |  | 15d | 2010-03-01 A | 2010-03-19 A | F4040 FF | 100% |  | ER361740 | ER361740 | 876 | 17 | 200 |  | E | R | ER36 | 1740 | 2 | LND |  |  | LND |  |  |  |
| HER49 |  | AG Piping Check/Release ISO's & BOM | level of effort | 183d | 2010-07-26 A | 2011-04-11 A | ER495104 SS, ER495103 SS, ER495101 SS, ER495102 SS | 100% |  | HER49 | HER49 | 873 | 17 | 200 |  | E | R | ER00 | 1740 | 5 | LND |  |  | LND |  |  | L2 |
| ER391740 |  | CA17 ExtrBldgFl6 - CAD Model Review 90% |  | 10d | 2010-09-06 A | 2010-09-17 A | F4462 FF | 100% |  | ER391740 | ER391740 | 876 | 17 | 200 |  | E | R | ER39 | 1740 | 3 | LND |  |  | LND |  |  |  |
| ER451740 |  | CA17 ExtrBldgFl6 - Piping Isometrics |  | 59d | 2010-09-27 A | 2010-12-17 A | ER301740 FF+10d, ER391740 FS+5d, ER421740, ER451736 SS | 100% |  | ER451740 | ER451740 | 876 | 17 | 200 |  | E | R | ER45 | 1740 | 5 | LND |  |  | LEI |  |  |  |
| ER45174005 |  | CA17 ExtrBldgFl6 - Piping Isometrics (ZEP) |  | 59d | 2010-09-27 A | 2010-12-17 A | ER301740 FF+10d, ER45173605 SS, ER391740 FS+5d, ER421740 | 100% |  | ER45174005 | ER45174005 | 876 | 17 | 200 |  | E | R | ER45 | 1740 | 5 | LND |  |  | ZEP |  |  |  |
| ER49174005 |  | CA17 ExtrBldgFl6 - Design Check/Rel.Isos&BOM ZEP |  | 94d | 2010-10-15 A | 2011-02-28 A | ER451740 SS+10d, ER45174005 SS+10d, E3R100 FF | 100% |  | ER49174005 | ER49174005 | 876 | 17 | 200 |  | E | R | ER49 | 1740 | 5 | LND |  |  | ZEP |  |  |  |
| ER491740 |  | CA17 ExtrBldgFl6 - Design Check/ Rel.Isos&BOM |  | 107d | 2010-11-09 A | 2011-04-11 A | ER451740 FF+20d, ER45174005 FF+20d, E3R100 FF, IMS-E-000110 FF | 100% |  | ER491740 | ER491740 | 876 | 17 | 200 |  | E | R | ER49 | 1740 | 5 | LND |  |  | LEI |  |  |  |

Notes:
- HER20: UDF_Actictity Name (Russia): Материалы трубопроводов - Технические анализ/спецификации заказов на поставку
- HER49: UDF_Actictity Name (Russia): Проверка/выпуск изометрических чертежей и спецификаций материалов надземных трубопроводов

| ID | WBS | Activity | Type | Duration | Start | Finish | Predecessors | Complete | Planned start | Planned finish | Resources | UDF_SAVE ACTID | UDF_SAVE ACT ID | Department | Constr. Area | PMT-Phase | PMT-Respons. | WBS Phase | WBS Discipline | WBS Type of Work | WBS Objects | IMS | UPT | Pro Unit/DocCode | PMT-Area | PMT-Schedule Org | Type of Work | Inquiry/Order No | PMT-Discipline | Zeigen/n. Zeigen | TB26 Ressource Budget |
| --- | --- | --- | --- | --- | --- | --- | --- | --- | --- | --- | --- | --- | --- | --- | --- | --- | --- | --- | --- | --- | --- | --- | --- | --- | --- | --- | --- | --- | --- | --- | --- |
|  | E | **E Electrical** |  |  | 2009-04-06 | 2011-02-14 |  |  |  |  |  |  |  |  |  |  |  |  |  |  |  |  |  |  |  |  |  |  |  |  |  |
| EE901740 |  | CA17 ExtrBldgFl6 - Earthing Details |  | 30d | 2009-04-06 A | 2009-05-20 A | EE901710 SS | 100% |  |  |  | EE901740 | EE901740 | 874 | 17 | E | LND | E | E | EE90 | 1740 | E | LND |  |  |  |  |  |  |  |  |
| EE46174010 |  | CA17 ExtrBldgFl6 - El. CableTray Layout Pl. / LOP's 1st Issue |  | 227d | 2009-12-07 A | 2010-10-29 A | F4040 FF+25d, EE460000 | 100% |  |  |  | EE46174010 | EE46174010 | 874 | 17 | E | LEI | E | E | EE46 | 1740 | E | LND |  |  |  |  |  |  |  |  |
| EE561740 |  | CA17 ExtrBldgFl6 - Cable Pulling Details |  | 297d | 2009-12-10 A | 2011-02-14 A | EE46174010 FF, EE500130 | 100% |  |  |  | EE561740 | EE561740 | 874 | 17 | E | LEI | E | E | EE56 | 1740 | E | LND |  |  |  |  |  |  |  |  |
|  | J | **J Instrumentation** |  |  | 2010-02-08 | 2010-12-15 |  |  |  |  |  |  |  |  |  |  |  |  |  |  |  |  |  |  |  |  |  |  |  |  |  |
| EJ361740 |  | CA17 ExtrBldgFl6 - Hook-Up drwgs 1st Issue |  | 99d | 2010-02-08 A | 2010-06-30 A | F4040 FF+55d, A1EJ0080 | 100% |  |  |  | EJ361740 | EJ361740 | 86E | 17 | C | LEI | E | J | EJ36 | 1740 | I | LND | 999 | 200 | 200 |  |  |  |  |  |
| EJ46174010 |  | CA17 ExtrBldgFl6 - Instr CableTray Layout Pl. 1st Issue |  | 150d | 2010-03-01 A | 2010-09-30 A | F4040 FF, EE46174010 FF | 100% |  |  |  | EJ46174010 | EJ46174010 | 86E | 17 | E | LEI | E | J | EJ41 | 1740 | I | LND | 999 |  |  |  |  |  |  |  |
| EJ801740 |  | CA17 ExtrBldgFl6 - Loop Diagrams |  | 79d | 2010-08-20 A | 2010-12-09 A | A1EJ0040 FF, EJ800010 | 100% |  |  |  | EJ801740 | EJ801740 | 86E | 17 | E | LEI | E | J | EJ80 | 1740 | I | LND | 999 |  |  |  |  |  |  |  |
| EJ321740 |  | CA17 ExtrBldgFl6 - JB Location drwgs |  | 67d | 2010-09-13 A | 2010-12-15 A | F4462 FF+20d, F4040 | 100% |  |  |  | EJ321740 | EJ321740 | 86E | 17 | C | LEI | E | J | EJ37 | 1740 | I | LND | 999 | 200 | 200 |  |  |  |  |  |
|  | 1760 | **1760 Purge Bin Structure +189,245m (+90,75m) - CA17** |  |  | 2008-03-03 | 2011-05-04 |  |  |  |  |  |  |  |  |  |  |  |  |  |  |  |  |  |  |  |  |  |  |  |  |  |
|  | 0B | **0B General Activities** |  |  | 2009-01-03 | 2009-01-03 |  |  |  |  |  |  |  |  |  |  |  |  |  |  |  |  |  |  |  |  |  |  |  |  |  |
| E0201760 |  | CA17 PurgeColStr - freeze construction concept | milestone | 0d | 2009-01-03 A | 2009-01-03 A | AD2230 FF | 100% |  |  |  | E0201760 | E0201760 | 87A | 17 | E |  | E | 0B | E020 | 1760 | INS | LND |  | 200 |  |  |  |  |  |  |
|  | N | **N Structural Steel** |  |  | 2008-03-03 | 2011-05-04 |  |  |  |  |  |  |  |  |  |  |  |  |  |  |  |  |  |  |  |  |  |  |  |  |  |
| EN151760 |  | CA17 PurgeColStr - CAD Model/Concepts StrSteel |  | 126d | 2008-03-03 A | 2008-08-29 A | AD2230 FF | 100% |  |  |  | EN151760 | EN151760 | 87B | 17 | E | LND | E | N | EN15 | 1760 | de | LND |  | 200 | 200 | N02T | N02T | 055 | 0 |  |
| EN21176005 |  | CA17 PurgeColStr SK1703 - GA-Drwgs + Fdtn Loads |  | 284d | 2009-02-16 A | 2010-04-02 A | EN21170105 SS, AD2230 FS+35d, EE46176005, EN151760 FF, ER161760, EJ46176005, E3A0840, E3ALL240 | 100% | 2009-02-16 | 2010-04-01 | TKB-S [480 h] | EN21176005 | EN21176005 | 87B | 17 |  | LND | E | N | EN21 | 1760 | de | LND |  | 200 |  | N02T | N02T |  |  | 480,00 |
| EN24176005 |  | CA17 PurgeColStr SK1703 -StaticCalc f.Fdtn Loads |  | 324d | 2009-11-16 A | 2011-02-28 A | EN21176005, P3C0BD | 100% |  |  | TKB-S [160 h] | EN24176005 | EN24176005 | 87B | 17 |  | LND | E | N | EN24 | 1760 | de | LND |  | 200 |  | N02T | N02T |  |  | 160,00 |
| EN251760 |  | CA17 PurgeColStr SK1703 - Loads for Civil | milestone | 0d | 2009-12-17 A | 2009-12-17 A | EN24176005 FF | 100% |  |  |  | EN251760 | EN251760 | 87B | 17 | E | LND | E | N | EN25 | 1760 | de | LND |  | 200 | 200 | N02T | N02T | 055 | 0 |  |
| EN21176010 |  | CA17 PurgeColStr SK1703 - GA-Drwgs + Final Loads |  | 124d | 2009-12-18 A | 2010-06-21 A | EN24176005, EE46176008 FF, EM051760, EB051760, EJ46176008 FF, EN251760 | 100% |  |  | TKB-S [1600 h] | EN21176010 | EN21176010 | 87B | 17 |  | LEI | E | N | EN21 | 1760 | de | LND |  | 200 |  | N02T | N02T |  |  | 1600,00 |
| EN24176010 |  | CA17 PurgeColStr SK1703 - Final Static Calc |  | 218d | 2010-01-25 A | 2010-12-01 A | EN21176010 SS+10d, ER191760 FF | 100% |  |  | TKB-S [1280 h] | EN24176010 | EN24176010 | 87B | 17 |  | LEI | E | N | EN24 | 1760 | de | LND |  | 200 |  | N02T | N02T |  |  | 1280,00 |
| EN671760 |  | CA17 PurgeColStr - Grating Cut-Out drwgs |  | 158d | 2010-06-28 A | 2011-02-07 A | F4462 FF, ER421760 FF, EN261760 FF+5d | 100% |  |  | TKB-S [720 h] | EN671760 | EN671760 | 87B | 17 | C | LEI | E | N | EN67 | 1760 | de | LND |  | 200 | 200 | N02T | N02T |  |  | 720,00 |
| EN261760 |  | CA17 PurgeColStr SK1703 - Layout dwgs input f.KM |  | 133d | 2010-07-26 A | 2011-01-31 A | EN24176010 FF, F4040 FF+20d | 100% |  |  | TKB-S [3200 h] | EN261760 | EN261760 | 87B | 17 |  | LEI | E | N | EN26 | 1760 | st | LND |  | 200 |  | N02T | N02T |  |  | 3200,00 |
| EN27176005 |  | CA17 PurgeColStr SK1703 - KM drwgs |  | 59d | 2010-12-13 A | 2011-03-07 A | EN24176005, EN261760 | 100% |  |  | KM Drwgs preparation by Cheljabinsk [674 t] | EN27176005 | EN27176005 | 87B | 17 |  | Chel | E | N | EN27 | 1760 | de | LND |  | 200 |  | N02T | N02T |  |  | 0,00 |
| EN641760 |  | CA17 PurgeColStr - Check Grating Cut-Out drwgs |  | 46d | 2011-01-03 A | 2011-03-07 A | EN671760 | 100% |  |  |  | EN641760 | EN641760 | 87B | 17 | C | LEI | E | N | EN67 | 1760 | de | LND |  | 200 | 200 | N02T | N02T |  |  |  |
| EN27176010 |  | CA17 PurgeColStr SK1703 - Check KM dwgs |  | 10d | 2011-03-03 A | 2011-03-16 A | EN27176005 FF+7d | 100% |  |  |  | EN27176010 | EN27176010 | 87B | 17 |  | LEI | E | N | EN27 | 1760 | de | LND |  | 200 |  | N02T | N02T |  |  |  |
| EN681760 |  | CA17 PurgeColStr - Grating Fabrication drwgs |  | 20d | 2011-03-08 A | 2011-04-04 A | EN641760, EN671760 | 100% |  |  |  | EN681760 | EN681760 | 87B | 17 | C | SC | E | N | EN68 | 1760 | de | LND |  | 200 | 200 | N02T | N02T |  |  |  |
| EN281760 |  | CA17 PurgeColStr SK1703 - Shop dwgs(KMD) by Vend |  | 35d | 2011-03-17 A | 2011-05-04 A | EN27176010, IMS-E-000180 FF | 100% |  |  |  | EN281760 | EN281760 | 87B | 17 |  | Chel | E | N | EN28 | 1760 | de | LND |  | 200 |  | N02T | N02T |  |  |  |

| ID | WBS | Activity | Type | Duration | Start | Finish | Predecessors | Complete | UDF_SAVE ACTID | UDF_SAVE ACT ID | Department | Constr. Area | PMT-Area | PMT-Respons. | WBS Phase | WBS Discipline | WBS Type of Work | WBS Objects | IMS | UPT | PMT-Phase | Type of Work | Inquiry/Order No | PMT-Schedule Org | PMT-Discipline | PMT-Doc. Type | Zeigen/n. Zeigen | Pro Unit/DocCode |
| --- | --- | --- | --- | --- | --- | --- | --- | --- | --- | --- | --- | --- | --- | --- | --- | --- | --- | --- | --- | --- | --- | --- | --- | --- | --- | --- | --- | --- |
|  | B | **B Mechanical - Stationary Equipment** |  |  | 2008-09-20 | 2008-09-20 |  |  |  |  |  |  |  |  |  |  |  |  |  |  |  |  |  |  |  |  |  |  |
| EB051760 |  | CA17 PurgeColStr - Final Loads for Struc Steel | milestone | 0d | 2008-09-20 A | 2008-09-20 A | E3A0840, E3ALL250 | 100% | EB051760 | EB051760 | 869 | 17 | 200 | LND | E | B | EB05 | 1760 | 3 | LND |  |  |  |  |  |  |  |  |
|  | M | **M Mechanical - Rotating Equipment** |  |  | 2009-01-31 | 2009-01-31 |  |  |  |  |  |  |  |  |  |  |  |  |  |  |  |  |  |  |  |  |  |  |
| EM051760 |  | CA17 PurgeColStr - Final Loads for Struc Steel | milestone | 0d | 2009-01-31 A | 2009-01-31 A | E3M1220 SF | 100% | EM051760 | EM051760 | 867 | 17 | 200 | LND | E | M | EM05 | 1760 | I | LND |  |  |  |  |  |  |  |  |
|  | R | **R Piping** |  |  | 2008-04-01 | 2011-04-11 |  |  |  |  |  |  |  |  |  |  |  |  |  |  |  |  |  |  |  |  |  |  |
| ER151760 |  | CA17 PurgeColStr - Conceptual Piping |  | 169d | 2008-04-01 A | 2008-11-28 A | F2760 | 100% | ER151760 | ER151760 | 876 | 17 | 200 | LND | E | R | ER15 | 1760 | PL | LND |  |  |  |  |  |  |  |  |
| ER301760 |  | CA17 PurgeColStr - CAD Model Piping / Eqpt |  | 579d | 2008-07-01 A | 2010-10-19 A | ER151760 SS, HER30 FF, E0201760 FF, ER391760 FF+10d | 100% | ER301760 | ER301760 | 876 | 17 | 200 | LNI | E | R | ER30 | 1760 | PL | LND |  |  |  |  |  |  |  |  |
| ER161760 |  | CA17 PurgeColStr - prel Loads for Steel Struc |  | 20d | 2009-01-05 A | 2009-01-30 A | ER151760 FF | 100% | ER161760 | ER161760 | 876 | 17 | 200 | LND | E | R | ER16 | 1760 | PL | LND |  |  |  |  |  |  |  |  |
| ER421760 |  | CA17 PurgeColStr - Stress Calculation |  | 98d | 2009-11-16 A | 2010-04-09 A | ER361760 | 100% | ER421760 | ER421760 | 872 | 17 | 200 | LND | E | R | ER42 | 1760 | PL | LND |  |  |  |  |  |  |  |  |
| ER361760 |  | CA17 PurgeColStr - CAD Model Review 60% |  | 15d | 2010-03-01 A | 2010-03-19 A | F4040 FF | 100% | ER361760 | ER361760 | 876 | 17 | 200 | LND | E | R | ER36 | 1760 | 2 | LND |  |  |  |  |  |  |  |  |
| ER191760 |  | CA17 PurgeColStr - Final Loads for Steel Struc | milestone | 0d | 2010-07-30 A | 2010-07-30 A | ER161760 FF, EN21176010 SF, F4040 FF+50d | 100% | ER191760 | ER191760 | 876 | 17 | 200 | LNI | E | R | ER19 | 1760 | PL | LND |  |  |  |  |  |  |  |  |
| ER391760 |  | CA17 PurgeColStr - CAD Model Review 90% |  | 10d | 2010-09-06 A | 2010-09-17 A | F4462 FF | 100% | ER391760 | ER391760 | 876 | 17 | 200 | LND | E | R | ER39 | 1760 | 3 | LND |  |  |  |  |  |  |  |  |
| ER451760 |  | CA17 PurgeColStr - Piping Isometrics |  | 59d | 2010-09-27 A | 2010-12-17 A | ER301760 FF+10d, ER421760, ER391760 FS+5d | 100% | ER451760 | ER451760 | 876 | 17 | 200 | LEI | E | R | ER45 | 1760 | 5 | LND |  |  |  |  |  |  |  |  |
| ER45176005 |  | CA17 PurgeColStr - Piping Isometrics (ZEP) |  | 59d | 2010-09-27 A | 2010-12-17 A | ER421760, ER391760 FS+5d, ER301760 FF+10d | 100% | ER45176005 | ER45176005 | 876 | 17 | 200 | ZEP | E | R | ER45 | 1760 | 5 | LND |  |  |  |  |  |  |  |  |
| ER49176005 |  | CA17 PurgeColStr - Design Check/Rel.Isos&BOM ZEP |  | 94d | 2010-10-15 A | 2011-02-28 A | ER451760 SF+10d, ER45176005 SS+10d | 100% | ER49176005 | ER49176005 | 876 | 17 | 200 | ZEP | E | R | ER49 | 1760 | 5 | LND |  |  |  |  |  |  |  |  |
| ER491760 |  | CA17 PurgeColStr - Design Check/ Rel.Isos&BOM |  | 107d | 2010-11-09 A | 2011-04-11 A | ER451760 FF+20d, HPR30 FF, IMS-E-000110 FF, HER49 FF, ER45176005 FF+20d | 100% | ER491760 | ER491760 | 876 | 17 | 200 | LEI | E | R | ER49 | 1760 | 5 | LND |  |  |  |  |  |  |  |  |
|  | E | **E Electrical** |  |  | 2008-10-06 | 2011-02-14 |  |  |  |  |  |  |  |  |  |  |  |  |  |  |  |  |  |  |  |  |  |  |
| EE46176005 |  | CA17 PurgeColStr - prelim Loads f. Struc Steel |  | 15d | 2008-10-06 A | 2008-10-24 A | F3060 FF | 100% | EE46176005 | EE46176005 | 874 | 17 |  | LND | E | E | EE11 | 1760 | E | LND | E |  |  |  |  |  |  |  |
| EE46176010 |  | CA17 PurgeColStr - El. CableTray Layout Pl. 1st Issue |  | 206d | 2009-12-07 A | 2010-09-30 A | F4040 FF+25d, EE460000 | 100% | EE46176010 | EE46176010 | 874 | 17 |  | LEI | E | E | EE46 | 1760 | E | LND | E |  |  |  |  |  |  |  |
| EE561760 |  | CA17 PurgeColStr - Cable Pulling Details |  | 297d | 2009-12-10 A | 2011-02-14 A | EE500130, EE46176010 FF | 100% | EE561760 | EE561760 | 874 | 17 |  | LEI | E | E | EE56 | 1760 | E | LND | E |  |  |  |  |  |  |  |
| EE46176008 |  | CA17 PurgeColStr - Final Loads f. Struc Steel |  | 20d | 2010-03-22 A | 2010-04-20 A | EE46176005 | 100% | EE46176008 | EE46176008 | 874 | 17 |  | LEI | E | E | EE12 | 1760 | E | LND | E |  |  |  |  |  |  |  |
| E3E1710 |  | E17 Aviation Lights - Inquiry Spec. |  | 10d | 2010-04-21 A | 2010-05-04 A | E3E0310 | 100% | E3E1710 | E3E1710 | 87E | 17 | 200 | LND | E | E | EE52 | 1760 | E | LND | E | E17 | 2EB6130 | 200 | 055 | DEV | 0 |  |
| E3E1720 |  | E17 Aviation Lights - Techn. Eval./PO Spec. (E&I SUB) |  | 110d | 2010-07-14 A | 2010-12-15 A | P3E17A FS+45d | 100% | E3E1720 | E3E1720 | 87E | 17 | 200 | CC | E | E | EE52 | 1760 | E | LND | E | E17 | 2EB6130 | 200 | 055 |  | 0 |  |
|  | J | **J Instrumentation** |  |  | 2008-10-06 | 2010-12-15 |  |  |  |  |  |  |  |  |  |  |  |  |  |  |  |  |  |  |  |  |  |  |
| EJ46176005 |  | CA17 PurgeColStr - prelimLoads f.Struc Steel |  | 15d | 2008-10-06 A | 2008-10-24 A | F3060 FF | 100% | EJ46176005 | EJ46176005 | 86E | 17 |  | LND | E | J | EJ11 | 1760 | I | LND | E |  |  |  |  |  |  | 999 |
| EJ361760 |  | CA17 PurgeColStr - Hook-Up drwgs 1st Issue |  | 99d | 2010-02-08 A | 2010-06-30 A | F4040 FF+55d, A1EJ0080 | 100% | EJ361760 | EJ361760 | 86E | 17 | 200 | LEI | E | J | EJ36 | 1760 | I | LND | C |  |  | 200 |  |  |  | 999 |
| EJ461760 |  | CA17 PurgeColStr - Instr Cable Tray Layout Pl. 1st Issue |  | 150d | 2010-03-01 A | 2010-09-30 A | F4040 FF, EE46176010 FF | 100% | EJ461760 | EJ461760 | 86E | 17 |  | LEI | E | J | EJ41 | 1760 | I | LND | E |  |  |  |  |  |  | 999 |
| EJ46176008 |  | CA17 PurgeColStr - Final Loads f.Struc Steel |  | 10d | 2010-04-07 A | 2010-04-20 A | EJ46176005 | 100% | EJ46176008 | EJ46176008 | 86E | 17 |  | LEI | E | J | EJ12 | 1760 | I | LND | E |  |  |  |  |  |  | 999 |
| EJ801760 |  | CA17 PurgeColStr - Loop Diagrams |  | 79d | 2010-08-20 A | 2010-12-09 A | EJ800010, A1EJ0040 FF | 100% | EJ801760 | EJ801760 | 86E | 17 |  | LEI | E | J | EJ80 | 1760 | I | LND | E |  |  |  |  |  |  | 999 |
| EJ321760 |  | CA17 PurgeColStr - JB Location drwgs |  | 67d | 2010-09-13 A | 2010-12-15 A | F4040, F4462 FF+20d | 100% | EJ321760 | EJ321760 | 86E | 17 | 200 | LEI | E | J | EJ37 | 1760 | I | LND | C |  |  | 200 |  |  |  | 999 |

| ID | WBS | Activity | Type | Duration | Start | Finish | Predecessors | Complete | Resources | UDF_SAVE ACTID | UDF_SAVE ACT ID | Department | Constr. Area | PMT-Area | PMT-Phase | WBS Phase | WBS Discipline | WBS Type of Work | WBS Objects | IMS | UPT | PMT-Respons. | PMT-Schedule Org | Type of Work | Inquiry/Order No | PMT-Discipline | Zeigen/n. Zeigen | TB26 Ressource Budget |
| --- | --- | --- | --- | --- | --- | --- | --- | --- | --- | --- | --- | --- | --- | --- | --- | --- | --- | --- | --- | --- | --- | --- | --- | --- | --- | --- | --- | --- |
|  | 1770 | **1770 Entrance Hall southside - CA17** |  |  | 2008-03-03 | 2011-05-02 |  |  |  |  |  |  |  |  |  |  |  |  |  |  |  |  |  |  |  |  |  |  |
|  | 0B | **0B General Activities** |  |  | 2009-01-03 | 2009-01-03 |  |  |  |  |  |  |  |  |  |  |  |  |  |  |  |  |  |  |  |  |  |  |
| E0201770 |  | CA17 ExtrBldgEntrHall - freeze constr. concept | milestone | 0d | 2009-01-03 A | 2009-01-03 A | AD2230 FF | 100% |  | E0201770 | E0201770 | 87A | 17 | 200 | E | E | 0B | E020 | 1770 | INS | LND |  |  |  |  |  |  |  |
|  | C | **C Civil** |  |  | 2008-03-03 | 2010-08-31 |  |  |  |  |  |  |  |  |  |  |  |  |  |  |  |  |  |  |  |  |  |  |
| EC421770 |  | CA17 ExtrBldgEntrHall - Building Concept |  | 181d | 2008-03-03 A | 2008-11-18 A | F2760 | 100% |  | EC421770 | EC421770 | 87A | 17 | 200 |  | E | C | EC42 | 1770 | cq | LND | LND |  |  |  |  |  |  |
| EC441770 |  | CA17 ExtrBldgEntrHall - Building Layout drwgs IFD |  | 20d | 2009-12-22 A | 2010-01-22 A | EC221770 FF, EC421770, AD2230 FF+30d, E0201770 | 100% |  | EC441770 | EC441770 | 87A | 17 | 200 |  | E | C | EC44 | 1770 | de | LND | LND |  |  |  |  |  |  |
| EC221770 |  | CA17 ExtrBldgEntrHall - Civil Foundation Loads |  | 15d | 2010-01-04 A | 2010-01-22 A | EN251770 FF+5d, EB051710 FF+5d | 100% |  | EC221770 | EC221770 | 87A | 17 | 200 |  | E | C | EC22 | 1770 | de | LND | LND |  |  |  |  |  |  |
| EC461770 |  | CA17 ExtrBldgEntrHall - Civil Static Calc Fdtn |  | 153d | 2010-01-25 A | 2010-08-31 A | EC461710 SS, P3C0BD FS+10d, EC441770 | 100% |  | EC461770 | EC461770 | 87A | 17 | 200 |  | E | C | EC46 | 1770 | de | LND | IPR |  |  |  |  |  |  |
| EC481770 |  | CA17 ExtrBldgEntrHall - Formw/Reinf drwgs AFC |  | 35d | 2010-06-09 A | 2010-07-27 A | EH241770 FF, EC461770 SS+20d | 100% |  | EC481770 | EC481770 | 87A | 17 | 200 | E | E | C | EC48 | 1770 | ar | LND | IPR | 200 |  |  |  |  |  |
|  | N | **N Structural Steel** |  |  | 2008-03-03 | 2011-05-02 |  |  |  |  |  |  |  |  |  |  |  |  |  |  |  |  |  |  |  |  |  |  |
| EN151770 |  | CA17 ExtrBldgEntrHall SK1702-CAD Model/Concepts Steel |  | 126d | 2008-03-03 A | 2008-08-29 A | AD2230 FF | 100% |  | EN151770 | EN151770 | 87B | 17 | 200 | E | E | N | EN15 | 1770 | de | LND | LND | 200 | N02S | N02S | 055 | 0 |  |
| EN21177005 |  | CA17 ExtrBldgEntrHall SK1702-GA-Drwgs + Fdtn Loads |  | 126d | 2009-02-23 A | 2009-08-24 A | EN21170105 FF, EH05171008, EJ46171005, AD2230 FF+15d, EE46171005, EN151770, ER161710 | 100% | TKB-S [480 h] | EN21177005 | EN21177005 | 87B | 17 | 200 |  | E | N | EN21 | 1770 | de | LND | LND |  | N02S | N02S |  |  | 480,00 |
| EN24177005 |  | CA17 ExtrBldgEntrHall SK1702- StaticCalc f.Fdtn Loads |  | 48d | 2009-10-12 A | 2009-12-17 A | EH05177008, EN21177005, P3C0BD | 100% |  | EN24177005 | EN24177005 | 87B | 17 | 200 |  | E | N | EN24 | 1770 | de | LND | LND |  | N02S | N02S |  |  |  |
| EN251770 |  | CA17 ExtrBldgEntrHall SK1702- Loads for Civil | milestone | 0d | 2009-12-17 A | 2009-12-17 A | EN24177005 FF | 100% |  | EN251770 | EN251770 | 87B | 17 | 200 | E | E | N | EN25 | 1770 | de | LND | LND | 200 | N02S | N02S | 055 | 0 |  |
| EN21177010 |  | CA17 ExtrBldgEntrHall SK1702- GA-Drwgs + Final Loads |  | 125d | 2009-12-18 A | 2010-06-22 A | EM051710, EN24177005, EE46171008, EJ46171008 FF, EN251701, F4040 SF+5d | 100% | TKB-S [800 h] | EN21177010 | EN21177010 | 87B | 17 | 200 |  | E | N | EN21 | 1770 | de | LND | LEI |  | N02S | N02S |  |  | 800,00 |
| EN24177010 |  | CA17 ExtrBldgEntrHall SK1702- Final Static Calc |  | 191d | 2010-02-22 A | 2010-11-22 A | EN21177010 SS+10d | 100% | TKB-S [640 h] | EN24177010 | EN24177010 | 87B | 17 | 200 |  | E | N | EN24 | 1770 | de | LND | IPR |  | N02S | N02S |  |  | 640,00 |
| EN261770 |  | CA17 ExtrBldgEntrHall SK1702- Layout dwgs input f.KM |  | 133d | 2010-06-25 A | 2010-12-30 A | EN24177010 FF+10d, F4040 FF+20d | 100% | TKB-S [2000 h] | EN261770 | EN261770 | 87B | 17 | 200 |  | E | N | EN26 | 1770 | st | LND | LEI |  | N02S | N02S |  |  | 2000,00 |
| EN671770 |  | CA17 ExtrBldgEntrHall SK1702- Grating Cut-Out drwgs |  | 156d | 2010-07-28 A | 2011-03-07 A | EN261770 FF+5d, F4462 FF+10d, ER421710 FF | 100% | TKB-S [880 h] | EN671770 | EN671770 | 87B | 17 | 200 | C | E | N | EN67 | 1770 | de | LND | LEI | 200 | N02S | N02S |  |  | 880,00 |
| EN27177005 |  | CA17 ExtrBldgEntrHall SK1702- KM drwgs |  | 54d | 2010-12-20 A | 2011-03-07 A | EN24177005, IMS-E-000120 FF, EN261770 FF+21d | 100% | KM Drwgs preparation by Cheljabinsk [320 t] | EN27177005 | EN27177005 | 87B | 17 | 200 |  | E | N | EN27 | 1770 | de | LND | Chel |  | N02S | N02S |  |  | 0,00 |
| EN27177010 |  | CA17 ExtrBldgEntrHall SK1702- Check KM dwgs |  | 10d | 2011-03-08 A | 2011-03-21 A | EN27177005 | 100% |  | EN27177010 | EN27177010 | 87B | 17 | 200 |  | E | N | EN27 | 1770 | de | LND | LEI |  | N02S | N02S |  |  |  |
| EN641770 |  | CA17 ExtrBldgEntrHal SK1702 - Check Grating Cut-Out drwgs |  | 20d | 2011-03-08 A | 2011-04-04 A | EN671770 | 100% |  | EN641770 | EN641770 | 87B | 17 | 200 | C | E | N | EN67 | 1770 | de | LND | LEI | 200 | N02S | N02S |  |  |  |
| EN271770 |  | CA17 ExtrBldgEntrHall SK1702-Shop dwgs(KMD) by Vend |  | 30d | 2011-03-22 A | 2011-05-02 A | EN27177010 | 100% |  | EN271770 | EN271770 | 87B | 17 | 200 |  | E | N | EN28 | 1770 | de | LND | Chel |  | N02S | N02S |  |  |  |
| EN681770 |  | CA17 ExtrBldgEntrHal SK1702- Grating Fabrication drwgs |  | 20d | 2011-04-05 A | 2011-05-02 A | EN641770, EN671770 | 100% |  | EN681770 | EN681770 | 87B | 17 | 200 | C | E | N | EN68 | 1770 | de | LND | SC | 200 | N02S | N02S |  |  |  |
|  | H | **H HVAC** |  |  | 2008-10-06 | 2010-09-24 |  |  |  |  |  |  |  |  |  |  |  |  |  |  |  |  |  |  |  |  |  |  |
| EH05177008 |  | CA17 ExtrBldgEntrHall - prelimLoads f.StrucSteel |  | 15d | 2008-10-06 A | 2008-10-24 A | EH201770 SS | 100% |  | EH05177008 | EH05177008 | 87C | 17 |  | E | E | H | EH11 | 1770 | OTH | LND | LND |  |  |  |  |  |  |
| EH201770 |  | CA17 ExtrBldgEntrHall - HVAC&Plumbing / Feed/Basic |  | 198d | 2008-10-06 A | 2009-07-24 A | AD2230 FF+20d | 100% |  | EH201770 | EH201770 | 87C | 17 | 200 | E | E | H | EH20 | 1770 | OTH | LND | LND | 200 |  |  | 035 |  |  |
| EH30177005 |  | CA17 ExtrBldgEntrHall - HVAC Layouts Dwgs AFC |  | 196d | 2009-12-15 A | 2010-09-24 A | EH30171005 SS, EH201770 | 100% |  | EH30177005 | EH30177005 | 87C | 17 | 200 | E | E | H | EH30 | 1770 | OTH | LND | IPR | 200 |  |  | 035 |  |  |
| EH30177010 |  | CA17 ExtrBldgEntrHall - HVAC Layouts Dwgs IFC | milestone | 0d | 2010-07-12 A | 2010-07-12 A | EH30177005 FF-8d | 100% |  | EH30177010 | EH30177010 | 87C | 17 | 200 | E | E | H | EH30 | 1770 | OTH | LND | IPR | 200 |  |  | 035 |  |  |
| EH30177015 |  | CA17 ExtrBldgEntrHall - Review HVAC Layout Dwgs |  | 49d | 2010-07-20 A | 2010-09-24 A | EH30177010 | 100% |  | EH30177015 | EH30177015 | 87C | 17 | 200 | E | E | H | EH30 | 1770 | OTH | LND | LND | 200 |  |  | 035 |  |  |
| EH051770 |  | CA17 ExtrBldgEntrHall - Final Loads f. StrSteel | milestone | 0d | 2010-09-15 A | 2010-09-15 A | EH30177005 FF-8d, E3H0150 SF | 100% |  | EH051770 | EH051770 | 87C | 17 | 200 |  | E | H | EH12 | 1770 | OTH | LND | IPR |  |  |  |  |  |  |
| EH241770 |  | CA17 ExtrBldgEntrHall - Wall&Fl. opening details | milestone | 0d | 2010-09-15 A | 2010-09-15 A | EH051770 FF, E3H0150 SF | 100% |  | EH241770 | EH241770 | 87C | 17 | 200 | E | E | H | EH24 | 1770 | OTH | LND | IPR | 200 |  |  | 035 |  |  |

Notes:
- EC421770: P3 Activity Log Info: fixed Layout
- EC441770: P3 Activity Log Info: incl. PMT approval
- EC221770: P3 Activity Log Info: TKB-B Keyplan to Subcontractor

| ID | WBS | Activity | Type | Duration | Start | Finish | Predecessors | Complete | Resources | Cost | Actual cost | UDF_SAVE ACTID | UDF_SAVE ACT ID | Department | Type of Work | Constr. Area | Pro Unit/DocCode | Inquiry/Order No | PMT-Area | PMT-Schedule Org | PMT-Discipline | PMT-Phase | PMT-Doc. Type | PMT-Respons. | Zeigen/n. Zeigen | WBS Phase | WBS Discipline | WBS Type of Work | WBS Objects | IMS | UPT | TB26 Ressource Budget | PMT-Stage |
| --- | --- | --- | --- | --- | --- | --- | --- | --- | --- | --- | --- | --- | --- | --- | --- | --- | --- | --- | --- | --- | --- | --- | --- | --- | --- | --- | --- | --- | --- | --- | --- | --- | --- |
|  | 31 | **31 CA31 - Storage / Packaging and Shipping Building** |  |  | 2008-01-22 | 2011-04-25 |  |  |  |  |  |  |  |  |  |  |  |  |  |  |  |  |  |  |  |  |  |  |  |  |  |  |  |
|  | LUZ2 | **LUZ2 General ( )** |  |  | 2008-01-22 | 2011-02-15 |  |  |  |  |  |  |  |  |  |  |  |  |  |  |  |  |  |  |  |  |  |  |  |  |  |  |  |
|  | U | **U Package Units** |  |  | 2008-01-22 | 2010-10-08 |  |  |  |  |  |  |  |  |  |  |  |  |  |  |  |  |  |  |  |  |  |  |  |  |  |  |  |
| F10200 |  | PU06 Bagging System - Concept Phase |  | 48d | 2008-01-22 A | 2008-03-31 A | F10400 FF | 100% |  |  |  | F10200 | F10200 | 869 | PU06 | 31 | DC | 2DC9010 | 200 | 200 | 055 | E | DEV | LND | C2 | E | U | EU33 | LUZ2 | 1 | LND |  |  |
| F10210 |  | PU06 Bagging System - PMT Approval Concept |  | 12d | 2008-04-02 A | 2008-04-17 A | F10200 | 100% |  |  |  | F10210 | F10210 | 869 | PU06 | 31 | DC | 2DC9010 | 200 | 200 | 055 | E |  | LND | C2 | E | U | EU33 | LUZ2 | 1 | LND |  |  |
| E3U0610 |  | PU06 Bagging System - Inquiry Spec. |  | 15d | 2008-04-23 A | 2008-05-15 A | F10210 | 100% |  |  |  | E3U0610 | E3U0610 | 869 | PU06 | 31 | DC | 2DC9010 | 200 | 200 | 055 | E | DEV | LND | C2 | E | U | EU33 | LUZ2 | 3 | LND |  |  |
| E3U0710 |  | PU07 Packaging Syst. - Inquiry Spec. |  | 13d | 2008-05-05 A | 2008-05-22 A | F10210 | 100% |  |  |  | E3U0710 | E3U0710 | 869 | PU07 | 31 | DC | 2DC9020 | 200 | 200 | 055 | E | DEV | LND | C2 | E | U | EU33 | LUZ2 | 3 | LND |  |  |
| E3U0720 |  | PU07 Packaging Syst. - Techn. Eval./PO Spec. |  | 354d | 2008-07-22 A | 2009-12-17 A | P3U07B FS+27d | 100% | TAA [400 h] |  |  | E3U0720 | E3U0720 | 869 | PU07 | 31 | DC | 2DC9020 | 200 | 200 | 055 | E |  | LND | C2 | E | U | EU34 | LUZ2 | 2 | LND | 400,00 |  |
| E3U0620 |  | PU06 Bagging System - Techn. Eval./PO Spec. |  | 372d | 2008-08-04 A | 2010-01-29 A | P3U06B FS+29d | 100% | TAA [400 h] |  |  | E3U0620 | E3U0620 | 869 | PU06 | 31 | DC | 2DC9010 | 200 | 200 | 055 | E |  | LND | C2 | E | U | EU34 | LUZ2 | 2 | LND | 400,00 |  |
| E3U0630 |  | PU06 Bagging System -Techn. Eval./Bid Tab Final | milestone | 0d | 2008-10-30 A | 2008-10-30 A | F10230 FF, E3U0620 FF-5d | 100% |  |  |  | E3U0630 | E3U0630 | 869 | PU06 | 31 | DC | 2DC9010 | 200 | 200 | 055 | E |  | LND | C2 | E | U | EU34 | LUZ2 | 2 | LND |  |  |
| E3U0730 |  | PU07 Packaging Syst. -Techn. Eval./Bid Tab Final | milestone | 0d | 2008-10-30 A | 2008-10-30 A | P3U07F FF, E3U0720 FF-5d | 100% |  |  |  | E3U0730 | E3U0730 | 869 | PU07 | 31 | DC | 2DC9020 | 200 | 200 | 055 | E |  | LND | C2 | E | U | EU34 | LUZ2 | 2 | LND |  |  |
| E3U0665 |  | 60% Design Review -downstream- (w/o Pack/Bagg Eqpt) | level of effort | 7d | 2009-10-19 A | 2009-10-27 A | F4035 SS, F4035 FF | 100% |  |  |  | E3U0665 | E3U0665 | 869 | PU06 | 31 | DC | 2DC9010 | 200 | 200 | 400 | E |  | LND | C2 | E | U | EU35 | LUZ2 | 3 | LND |  |  |
| E3U0765 |  | 60% Design Review -downstream- (w/o Pack/Bagg Eqpt) | level of effort | 7d | 2009-10-19 A | 2009-10-27 A | F4035 FF, F4035 SS | 100% |  |  |  | E3U0765 | E3U0765 | 869 | PU07 | 31 | DC | 2DC9020 | 200 | 200 | 400 | E |  | LND | C2 | E | U | EU35 | LUZ2 | 3 | LND |  |  |
| E3U0740 |  | PU07 Packaging Syst. - 1st Review Vendor Dwgs |  | 16d | 2010-02-18 A | 2010-03-11 A | P3U07D FS+40d | 100% | TAA [1600 h] |  |  | E3U0740 | E3U0740 | 869 | PU07 | 31 | DC | 2DC9020 | 200 | 200 | 400 | E | DFA | LND | C2 | E | U | EU35 | LUZ2 | 3 | LND | 1600,00 |  |
| E3U0640 |  | PU06 Bagging System - 1st Review Vendor Dwgs |  | 12d | 2010-03-04 A | 2010-03-19 A | P3U06D FS+20d, P3U06L SS+25d, HEB50 FF | 100% | TAA [1200 h] |  |  | E3U0640 | E3U0640 | 869 | PU06 | 31 | DC | 2DC9010 | 200 | 200 | 400 | E | DFA | LND | C2 | E | U | EU35 | LUZ2 | 3 | LND | 1200,00 |  |
| E3U0750 |  | PU07 Packaging Syst. - Vendor dwgs approved | milestone | 0d | 2010-03-11 A | 2010-03-11 A | E3U0740 FF | 100% |  | 384,950 | 384,950 | E3U0750 | E3U0750 | 869 | PU07 | 31 | DC | 2DC9020 | 200 | 200 | 400 | E |  | LND | C2 | E | U | EU35 | LUZ2 | 3 | LND |  |  |
| E3U0650 |  | PU06 Bagging System - Vendor dwgs approved | milestone | 0d | 2010-03-19 A | 2010-03-19 A | E3U0640 FF | 100% |  | 217,770.8 | 217,770.8 | E3U0650 | E3U0650 | 869 | PU06 | 31 | DC | 2DC9010 | 200 | 200 | 400 | E |  | LND | C2 | E | U | EU35 | LUZ2 | 3 | LND |  |  |
| E3U0760 |  | PU07 Packaging Syst. - 2nd Review Vendor Dwgs (incl. Instr. Data Sheets/PLC/JB) |  | 128d | 2010-04-12 A | 2010-10-08 A | E3U0750 FS+10d | 100% | TAA [800 h] |  |  | E3U0760 | E3U0760 | 869 | PU07 | 31 | DC | 2DC9020 | 200 | 200 | 400 | E |  | LND | C2 | E | U | EU35 | LUZ2 | 3 | LND | 800,00 |  |
| E3U0666 |  | 60% Design Review -downstream- (Pack/Bagg Eqpt) | level of effort | 10d | 2010-04-26 A | 2010-05-07 A | F9250 FF, F9250 SS | 100% |  |  |  | E3U0666 | E3U0666 | 869 | PU06 | 31 | DC | 2DC9010 | 200 | 200 | 400 | E |  | LND | C2 | E | U | EU35 | LUZ2 | 3 | LND |  |  |
| E3U0667 |  | 90% Design Review -downstream- | level of effort | 10d | 2010-04-26 A | 2010-05-07 A | F9250 SS, E3U0665, F9250 FF, E3U0765, E3U0666, E3U0766 | 100% |  |  |  | E3U0667 | E3U0667 | 869 | PU06 | 31 | DC | 2DC9010 | 200 | 200 | 400 | E |  | LND | C2 | E | U | EU35 | LUZ2 | 3 | LND |  |  |
| E3U0766 |  | 60% Design Review -downstream- (Pack/Bagg Eqpt) | level of effort | 10d | 2010-04-26 A | 2010-05-07 A | F9250 FF, F9250 SS | 100% |  |  |  | E3U0766 | E3U0766 | 869 | PU07 | 31 | DC | 2DC9020 | 200 | 200 | 400 | E |  | LND | C2 | E | U | EU35 | LUZ2 | 3 | LND |  |  |
| E3U0767 |  | 90% Design Review -downstream- | level of effort | 10d | 2010-04-26 A | 2010-05-07 A | F9250 SS, F9250 FF | 100% |  |  |  | E3U0767 | E3U0767 | 869 | PU07 | 31 | DC | 2DC9020 | 200 | 200 | 400 | E |  | LND | C2 | E | U | EU35 | LUZ2 | 3 | LND |  |  |
| E3U0660 |  | PU06 Bagging System - 2nd Review Vendor Dwgs (incl. Instr. Data Sheets/PLC/JB) |  | 106d | 2010-05-12 A | 2010-10-08 A | IMS-E-000060 FF, P3U06D FS+52d, E3U0650 FS+35d | 100% | TAA [800 h] |  |  | E3U0660 | E3U0660 | 869 | PU06 | 31 | DC | 2DC9010 | 200 | 200 | 400 | E |  | LND | C2 | E | U | EU35 | LUZ2 | 3 | LND | 800,00 |  |
|  | B | **B Mechanical - Stationary Equipment** |  |  | 2008-01-22 | 2011-01-31 |  |  |  |  |  |  |  |  |  |  |  |  |  |  |  |  |  |  |  |  |  |  |  |  |  |  |  |
| F5457 |  | ALL4 Silo's - Concept Phase |  | 48d | 2008-01-22 A | 2008-03-31 A | F10400 SS | 100% |  |  |  | F5457 | F5457 | 869 | ALL4 | 31 | DC | 2DC9000 | 200 | 200 | 055 | E | DEV | LND |  | E | B | EB19 | LUZ2 | 1 | LND |  | 3A |
| F5467 |  | ALL4 Silo's - PMT approve Concept |  | 12d | 2008-04-02 A | 2008-04-17 A | F5457 | 100% |  |  |  | F5467 | F5467 | 869 | ALL4 | 31 | DC | 2DC9000 | 200 | 200 | 055 | E | DEV | LND |  | E | B | EB19 | LUZ2 | 1 | LND |  | 3A |
| E3ALL420 |  | ALL4 Silo's - Techn. Eval./PO Spec. |  | 28d | 2008-06-25 A | 2008-08-01 A | F10050 SS | 100% |  |  |  | E3ALL420 | E3ALL420 | 869 | ALL4 | 31 | DC | 2DC9000 | 200 | 200 | 400 | E |  | LND | C2 | E | B | EB64 | LUZ2 | 3 | LND |  |  |
| E3ALL430 |  | ALL4 Silo's - Techn. Eval./Bid Tab Finalized | milestone | 0d | 2008-07-23 A | 2008-07-23 A | E3ALL420 FF-5d | 100% |  |  |  | E3ALL430 | E3ALL430 | 869 | ALL4 | 31 | DC | 2DC9000 | 200 | 200 | 055 | E |  | LND | C2 | E | B | EB64 | LUZ2 | 3 | LND |  |  |
| E3ALL440 |  | ALL4 Silo's - 1st review Vendor Dwgs |  | 12d | 2008-09-15 A | 2008-09-30 A | P3ALL4D1 FS+20d | 100% |  |  |  | E3ALL440 | E3ALL440 | 869 | ALL4 | 31 | DC | 2DC9000 | 200 | 200 | 400 | E | DFA | LND | C2 | E | B | EB65 | LUZ2 | 3 | LND |  |  |
| E3ALL450 |  | ALL4 Silo's - Vendor dwgs approved | milestone | 0d | 2008-10-01 A | 2008-10-01 A | E3ALL440 FF | 100% |  | 774,580 | 774,580 | E3ALL450 | E3ALL450 | 869 | ALL4 | 31 | DC | 2DC9000 | 200 | 200 | 400 | E |  | LND | C2 | E | B | EB65 | LUZ2 | 3 | LND |  |  |
| E3ALL460 |  | ALL4 Silo's - 2nd Review Vendor Dwgs |  | 10d | 2009-01-08 A | 2009-01-21 A | P3ALL4D1 FS+105d, E3ALL450 | 100% |  |  |  | E3ALL460 | E3ALL460 | 869 | ALL4 | 31 | DC | 2DC9000 | 200 | 200 | 400 | E |  | LND | C2 | E | B | EB65 | LUZ2 | 3 | LND |  |  |
| E3ALL470 |  | ALL4 Silo's - Review Final Documentation |  | 256d | 2010-01-28 A | 2011-01-31 A | P3ALL4L FS+20d | 100% | TAA [800 h] |  |  | E3ALL470 | E3ALL470 | 869 | ALL4 | 31 | DC | 2DC9000 | 200 | 200 | 400 | E |  | LND | C2 | E | B | EB65 | LUZ2 | 3 | LND | 800,00 |  |

Notes:
- E3U0750: Expenses: 900A 384950
- E3U0650: Expenses: 900A 217771
- E3ALL450: Expenses: 900A 774580

| ID | WBS | Activity | Type | Duration | Start | Finish | Predecessors | Complete | Planned start | Planned finish | Resources | TB26 Ressource Budget | UDF_SAVE ACTID | UDF_SAVE ACT ID | Department | Type of Work | Constr. Area | Pro Unit/DocCode | Inquiry/Order No | PMT-Area | PMT-Schedule Org | PMT-Discipline | PMT-Phase | PMT-Respons. | Zeigen/n. Zeigen | WBS Phase | WBS Discipline | WBS Type of Work | WBS Objects | IMS | UPT |
| --- | --- | --- | --- | --- | --- | --- | --- | --- | --- | --- | --- | --- | --- | --- | --- | --- | --- | --- | --- | --- | --- | --- | --- | --- | --- | --- | --- | --- | --- | --- | --- |
|  | M | **M Mechanical - Rotating Equipment** |  |  | 2010-01-26 | 2011-02-15 |  |  |  |  |  |  |  |  |  |  |  |  |  |  |  |  |  |  |  |  |  |  |  |  |  |
| E3M0270 |  | M02 Recycle Gas Compr. - Review Final Documentation |  | 178d | 2010-01-26 A | 2010-10-06 A | P3M02L, E3M0265 | 100% |  |  | TAM [1600 h] | 1600,00 | E3M0270 | E3M0270 | 869 | M02 | 31 | DC | 2DC8490 | 200 | 200 | 400 | E | LND | C2 | E | M | EM15 | LUZ2 | 3 | LND |
| E3M0670 |  | M06 R. Tepid Pumps - Review Final Documentation |  | 132d | 2010-03-25 A | 2010-09-30 A | P3M06L FF-50d | 100% |  |  | TAM [400 h] | 400,00 | E3M0670 | E3M0670 | 869 | M06 | 31 | DC | 2PA6540 | 200 | 200 | 400 | E | LND | C2 | E | M | EM25 | LUZ2 | 3 | LND |
| E3M0570 |  | M05 R. Quench Pumps - Review Final Documentation |  | 126d | 2010-03-29 A | 2010-09-24 A | P3M05L FF-50d | 100% |  |  | TAM [480 h] | 480,00 | E3M0570 | E3M0570 | 869 | M05 | 31 | DC | 2PA6550 | 200 | 200 | 400 | E | LND | C2 | E | M | EM25 | LUZ2 | 3 | LND |
| E3M0770 |  | M07 Cat Feed Pumps - Review Final Documentation |  | 133d | 2010-04-26 A | 2010-10-29 A | P3M07L FF-15d | 100% |  |  | TAM [480 h] | 480,00 | E3M0770 | E3M0770 | 869 | M07 | 31 | DC | 2PA6670 | 200 | 200 | 400 | E | LND | C2 | E | M | EM25 | LUZ2 | 3 | LND |
| E3M1070 |  | M10 Catalyst Waste Pumps - Review Final Documentation |  | 115d | 2010-04-26 A | 2010-10-05 A | P3M10L FF-10d | 100% |  |  | TAM [320 h] | 320,00 | E3M1070 | E3M1070 | 869 | M10 | 31 | DC | 2PA6690 | 200 | 200 | 400 | E | LND | C2 | E | M | EM25 | LUZ2 | 3 | LND |
| E3M1170 |  | M11 RA Gear Unit - Review Final Documentation |  | 207d | 2010-04-26 A | 2011-02-15 A | P3M11L FF-10d, E3M1165 | 100% |  |  | TAM [1600 h] | 1600,00 | E3M1170 | E3M1170 | 869 | M11 | 31 | DC | 2KB4290 | 200 | 200 | 400 | E | LND | C2 | E | M | EM95 | LUZ2 | 3 | LND |
| E3M1270 |  | M12 Rotary Feeder - Review Final Documentation |  | 133d | 2010-04-26 A | 2010-10-29 A | P3M12L FF-20d | 100% |  |  | TAM [960 h] | 960,00 | E3M1270 | E3M1270 | 869 | M12 | 31 | DC | 2DC8940 | 200 | 200 | 400 | E | LND | C2 | E | M | EM95 | LUZ2 | 3 | LND |
| E3M0370 |  | M03 Offgas Compr. - Review Final Documentation (incl. Instr. Data Sheets / PLC / JB) |  | 102d | 2010-05-17 A | 2010-10-06 A | P3M03L FF-10d, P3M0370 | 100% |  |  | TAM [1600 h] | 1600,00 | E3M0370 | E3M0370 | 869 | M03 | 31 | DC | 2DC8460 | 200 | 200 | 400 | E | LND | C2 | E | M | EM15 | LUZ2 | 3 | LND |
| E3M1670 |  | M16 Instrument Air Compr. - Review Final Documentation |  | 162d | 2010-05-31 A | 2011-01-14 A | E3M1675, P3M01AL FF-45d, P3M16L FF-45d | 100% |  |  | TAM [1600 h] | 1600,00 | E3M1670 | E3M1670 | 869 | M16 | 31 | DC | 2KB4660 | 200 | 200 | 400 | E | LND | C2 | E | M | EM15 | LUZ2 | 3 | LND |
| E3M1175 |  | M11 RA Gear Unit - Review Instr. Data Sheets / JB |  | 41d | 2010-06-23 A | 2010-08-18 A | E3M1170 SS+40d | 100% |  |  |  |  | E3M1175 | E3M1175 | 869 | M11 | 31 | DC | 2KB4290 | 200 | 200 | 400 | E | LND | C2 | E | M | EM95 | LUZ2 | 3 | LND |
| E3M0870 |  | M08 Teal/Donor Feed Pumps - Review Final Documentation |  | 50d | 2010-07-28 A | 2010-10-05 A | P3M08L FS+20d | 100% |  |  | TAM [480 h] | 480,00 | E3M0870 | E3M0870 | 869 | M08 | 31 | DC | 2PA6690 | 200 | 200 | 400 | E | LND | C2 | E | M | EM25 | LUZ2 | 3 | LND |
| E3M1570 |  | M15 Conds./BoosterP. - Review Final Documentation |  | 63d | 2010-07-28 A | 2010-10-22 A | P3M15L FF-10d | 100% |  |  | TAM [400 h] | 400,00 | E3M1570 | E3M1570 | 869 | M15 | 31 | DC | 2PA6720 | 200 | 200 | 400 | E | LND | C2 | E | M | EM25 | LUZ2 | 3 | LND |
| E3M0970 |  | M09 Unloading Pumps - Review Final Documentation |  | 5d | 2010-10-18 A | 2010-10-22 A | P3M09L SS+20d | 100% |  |  | TAM | 0,00 | E3M0970 | E3M0970 | 869 | M09 | 31 | DC | 2PA6680 | 200 | 200 | 400 | E | LND | C2 | E | M | EM25 | LUZ2 | 3 | LND |
|  | 3100 | **3100 Generals - CA31** |  |  | 2008-07-14 | 2011-04-25 |  |  |  |  |  |  |  |  |  |  |  |  |  |  |  |  |  |  |  |  |  |  |  |  |  |
|  | C | **C Civil** |  |  | 2008-07-14 | 2011-04-25 |  |  |  |  |  |  |  |  |  |  |  |  |  |  |  |  |  |  |  |  |  |  |  |  |  |
| EC443100 |  | CA31 General - Civil Layout drwgs / Loads IFD | level of effort | 257d | 2008-07-14 A | 2009-07-24 A |  | 100% |  |  |  |  | EC443100 | EC443100 | 87A |  | 31 | 3100C01 | 999 | 200 |  |  | E | LND |  | E | C | EC44 | 3100 | de | LND |
| EC60310002 |  | CA95 Overall - Roads Layout drwgs / Loads IFD | level of effort | 257d | 2008-07-14 A | 2009-07-24 A |  | 100% |  |  |  |  | EC60310002 | EC60310002 | 87A |  | 31 | 9531C01 | 999 | 200 |  |  | E | LND |  | E | C | EC44 | 3100 | de | LND |
| EC60310010 |  | CA96 Overall - Paving (down) Layout drwgs / Loads IFD | level of effort | 257d | 2008-07-14 A | 2009-07-24 A |  | 100% |  |  |  |  | EC60310010 | EC60310010 | 87A |  | 31 | 9631C01 | 999 | 200 |  |  | E | LND |  | E | C | EC44 | 3100 | de | LND |
| EC60310004 |  | CA95 Overall - Roads (down) Calculations | level of effort | 444d | 2009-07-27 A | 2011-04-25 A | EC60310002 | 100% |  |  |  |  | EC60310004 | EC60310004 | 87A |  | 31 | 9531C14 | 999 | 200 | 200 |  | E | LNK |  | E | C | EC60 | 3100 | de | LND |
| EC073100 |  | CA31 General - Check & Release of working drwgs (AFC) |  | 349d | 2009-10-12 A | 2011-02-28 A | EC45311005 SS+30d, EC603110 FF+5d | 100% |  |  | TKB-B [11536 h] | 11536,00 | EC073100 | EC073100 | 87A |  | 31 |  | 999 | 200 |  |  | E | LND | FL | E | C | EC07 | 3100 | cq | LND |
| EC073105 |  | CA31 General - Issue of working drwgs (AFC) by RDI |  | 379d | 2009-10-12 A | 2011-04-11 A | EC603110 FF, EC603120 FF, EC603130 FF, EC153110 SS+25d | 100% |  |  | TKB-B [50640 h] | 50640,00 | EC073105 | EC073105 | 87A |  | 31 | 1010C13 | 999 | 200 |  |  | E | LNK | FL | E | C | EC07 | 3100 | cq | LND |
| EC44310005 |  | CA31 General - General Drwgs & Documents |  | 329d | 2009-12-22 A | 2011-04-11 A | EC073100 FF | 100% |  |  | TKB-B [2960 h] | 2960,00 | EC44310005 | EC44310005 | 87A |  | 31 | 3100C11 | 999 | 200 |  |  | E | LNK |  | E | C | EC00 | 3100 | de | LND |
|  | N | **N Structural Steel** |  |  | 2009-12-07 | 2011-03-24 |  |  |  |  |  |  |  |  |  |  |  |  |  |  |  |  |  |  |  |  |  |  |  |  |  |
| EN21310010 |  | CA31 Supports SK3106 - GA-Drwgs + Final Loads |  | 28d | 2009-12-07 A | 2010-01-19 A | EN21311010, EN21313010 FS+10d, EN21312010 FS+5d, EN21314010 | 100% |  |  | TKB-S [2400 h] | 2400,00 | EN21310010 | EN21310010 | 87B | N02" | 31 |  | N02" | 200 |  |  |  | LND |  | E | N | EN21 | 3100 | de | LND |
| EN24310010 |  | CA31 Supports SK3106 - Final Static Calc |  | 56d | 2010-01-20 A | 2010-04-09 A | EN21310010 | 100% |  |  |  |  | EN24310010 | EN24310010 | 87B | N02" | 31 |  | N02" | 200 |  |  |  | LNK |  | E | N | EN24 | 3100 | de | LND |
| EN263100 |  | CA31 Supports SK3106 - Layout dwgs input KM dwg |  | 100d | 2010-04-01 A | 2010-08-24 A | EN24310010 FF+15d, EN24311010 SS+20d, F4035 FF+20d | 100% |  |  | TKB-S [2800 h] | 2800,00 | EN263100 | EN263100 | 87B | N02" | 31 |  | N02" | 200 |  |  |  | LND |  | E | N | EN26 | 3100 | st | LND |
| EN27310005 |  | CA31 Supports SK3106 - KM drwgs |  | 90d | 2010-08-25 A | 2010-12-31 A | EN263100, EN24311005 | 100% | 2010-08-25 | 2010-12-30 |  |  | EN27310005 | EN27310005 | 87B | N02" | 31 |  | N02" | 200 |  |  |  | Chel |  | E | N | EN27 | 3100 | de | LND |
| EN27310010 |  | CA31 Supports SK3106 - Check KM drwgs |  | 10d | 2011-01-13 A | 2011-01-27 A | EN27310005 FS+5d | 100% |  |  |  |  | EN27310010 | EN27310010 | 87B | N02" | 31 |  | N02" | 200 |  |  |  | LND |  | E | N | EN27 | 3100 | de | LND |
| EN283100 |  | CA31 Supports SK3106 - Shop dwgs(KMD) by Vendor |  | 40d | 2011-01-27 A | 2011-03-24 A | EN27310010 | 100% |  |  |  |  | EN283100 | EN283100 | 87B | N02" | 31 |  | N02" | 200 |  |  |  | Chel |  | E | N | EN28 | 3100 | de | LND |

Notes:
- EC443100: P3 Activity Log Info: incl. PMT approval
- EC60310002: P3 Activity Log Info: incl. PMT approval
- EC60310010: P3 Activity Log Info: incl. PMT approval
- EC60310004: P3 Activity Log Info: incl. Catch Basin and Pulling Pits
- EC44310005: P3 Activity Log Info: incl. PMT / approval

| ID | WBS | Activity | Type | Duration | Start | Finish | Predecessors | Complete | Resources | UDF_SAVE ACTID | UDF_SAVE ACT ID | Department | Constr. Area | Inquiry/Order No | PMT-Area | PMT-Phase | WBS Phase | WBS Discipline | WBS Type of Work | WBS Objects | IMS | UPT | PMT-Respons. | Pro Unit/DocCode | Zeigen/n. Zeigen | PMT-Schedule Org | Type of Work | PMT-Discipline | TB26 Ressource Budget |
| --- | --- | --- | --- | --- | --- | --- | --- | --- | --- | --- | --- | --- | --- | --- | --- | --- | --- | --- | --- | --- | --- | --- | --- | --- | --- | --- | --- | --- | --- |
|  | 3110 | **3110 Silo Structure - CA31** |  |  | 2008-03-03 | 2011-03-21 |  |  |  |  |  |  |  |  |  |  |  |  |  |  |  |  |  |  |  |  |  |  |  |
|  | 0B | **0B General Activities** |  |  | 2009-01-03 | 2009-01-03 |  |  |  |  |  |  |  |  |  |  |  |  |  |  |  |  |  |  |  |  |  |  |  |
| E0203110 |  | CA31 SiloStruc - freeze constr. concept | milestone | 0d | 2009-01-03 A | 2009-01-03 A | F3600 | 100% |  | E0203110 | E0203110 | 87A | 31 | 999 | 200 | E | E | 0B | E020 | 3110 | INS | LND |  |  |  |  |  |  |  |
|  | C | **C Civil** |  |  | 2008-03-03 | 2011-03-21 |  |  |  |  |  |  |  |  |  |  |  |  |  |  |  |  |  |  |  |  |  |  |  |
| EC423110 |  | CA31 SiloStruc - Building Concept |  | 165d | 2008-03-03 A | 2008-10-24 A | F2760 | 100% |  | EC423110 | EC423110 | 87A | 31 | 999 | 200 |  | E | C | EC42 | 3110 | cq | LND | LND |  |  |  |  |  |  |
| EC443110 |  | CA31 SiloStruc - Building Layout drwgs IFD |  | 256.75d | 2008-07-14 A | 2009-07-24 A | EC443100 FF, EC223110 FF, EC60310010 FF, EC60310002 FF, AD2230 FF, EC423110 FF, E0203110 | 100% |  | EC443110 | EC443110 | 87A | 31 | 999 | 200 |  | E | C | EC44 | 3110 | cq | LND | LND | 3101C01 |  |  |  |  |  |
| EC223110 |  | CA31 SiloStruc - Civil Foundation Loads |  | 20d | 2009-06-22 A | 2009-07-17 A | E3ALL440 FF+4d, EN253110 SS | 100% |  | EC223110 | EC223110 | 87A | 31 | 999 | 200 |  | E | C | EC22 | 3110 | de | LND | LND |  |  |  |  |  |  |
| EC45311005 |  | CA31 SiloStruc - Building Layout drwgs AFC |  | 214d | 2009-08-24 A | 2010-06-30 A | P3C00D FS+5d, EC443110, AD2230, EC48100 | 100% |  | EC45311005 | EC45311005 | 87A | 31 | 999 | 200 | E | E | C | EC45 | 3110 | ar | LND | LNK | 3101C13 |  |  |  |  |  |
| EC133100 |  | CA31 SiloStruc - Fire Safety Survey Report |  | 384d | 2009-09-07 A | 2011-03-14 A | EC463110 SS | 100% |  | EC133100 | EC133100 | 87A | 31 | 999 | 200 |  | E | C | EC13 | 3110 | de | LND | LNK | 3100C15 | C1 |  |  |  |  |
| EC153110 |  | CA31 SiloStruc - Piling drwgs AFC |  | 40d | 2009-09-07 A | 2009-10-30 A | EC463110 SS, EC15000010 | 100% |  | EC153110 | EC153110 | 87A | 31 | 999 | 200 |  | E | C | EC15 | 3110 | PI | LND | LNK | 3101C16 | C1 |  |  |  |  |
| EC463110 |  | CA31 SiloStruc - Civil Static Calculation Found. |  | 93d | 2009-09-07 A | 2010-01-20 A | EC45311005 SS+10d, EC443110, EC463140 SS, P3C00D, P3C00E | 100% |  | EC463110 | EC463110 | 87A | 31 | 999 | 200 |  | E | C | EC46 | 3110 | de | LND | LNK | 3101C14 | C1 |  |  |  |  |
| EC28311003 |  | CA31 SiloStruc - Formw/Reinf drwgs Struc Found. AFC |  | 132d | 2009-09-21 A | 2010-03-30 A | EC45311005 SS+20d, EC463110 FF-4d, EC153110 SS+10d | 100% |  | EC28311003 | EC28311003 | 87A | 31 | 999 | 200 | E | E | C | EC48 | 3110 | ar | LND | LNK | 3101C21 |  | 200 |  |  |  |
| EC28311004 |  | CA31 SiloStruc - Precast Layout drwgs AFC >10,50m |  | 167d | 2009-09-28 A | 2010-05-31 A | EC45311005 SS+25d, EC153110 SS+15d | 100% |  | EC28311004 | EC28311004 | 87A | 31 | 999 | 200 | E | E | C | EC48 | 3110 | PRE | LND | LNK | 3101C31 |  | 200 |  |  |  |
| EC28311005 |  | CA31 SiloStruc - Formw/Reinf drwgs Str GF +0,00m AFC |  | 122d | 2009-10-05 A | 2010-03-30 A | EC28311003 SS+10d, EC463110 FF+10d, EC45311005 SS+30d | 100% |  | EC28311005 | EC28311005 | 87A | 31 | 999 | 200 | E | E | C | EC48 | 3110 | ar | LND | LNK | 3101C22 |  | 200 |  |  |  |
| EC28311007 |  | CA31 SiloStruc - Formw/Reinf drwgs Struc +6,00m AFC |  | 162d | 2009-10-05 A | 2010-05-31 A | EC28311005 FF | 100% |  | EC28311007 | EC28311007 | 87A | 31 | 999 | 200 | E | E | C | EC48 | 3110 | ar | LND | LNK | 3101C23 |  | 200 |  |  |  |
| EC28311010 |  | CA31 SiloStruc - Formw/Reinf drwgs Struc +10,50m AFC |  | 162d | 2009-10-05 A | 2010-05-31 A | EC28311007 FF | 100% |  | EC28311010 | EC28311010 | 87A | 31 | 999 | 200 | E | E | C | EC48 | 3110 | ar | LND | LNK | 3101C24 |  | 200 |  |  |  |
| EC28311012 |  | CA31 SiloStruc - Formw/Reinf drwgs Struc +23,50m AFC |  | 162d | 2009-10-05 A | 2010-05-31 A | EC28311010 FF | 100% |  | EC28311012 | EC28311012 | 87A | 31 | 999 | 200 | E | E | C | EC48 | 3110 | ar | LND | LNK | 3101C25 |  | 200 |  |  |  |
| EC28311009 |  | CA31 SiloStruc - Precast Formw/Reinf. drwgs AFC <23,50m |  | 147d | 2009-10-26 A | 2010-05-31 A | EC28311004 FF | 100% |  | EC28311009 | EC28311009 | 87A | 31 | 999 | 200 | E | E | C | EC48 | 3110 | ar | LND | LNK | 3101C55 |  | 200 |  |  |  |
| EC503110 |  | CA31 SiloStruc - Architec Det.drwgs Bldg AFC |  | 334d | 2009-11-24 A | 2011-03-21 A | EC28311012 FF+15d | 100% |  | EC503110 | EC503110 | 87A | 31 | 999 | 200 | E | E | C | EC50 | 3110 | ar | LND | LNK | 3101C41 |  | 200 |  |  |  |
| EC603110 |  | CA31 SiloStruc - Paving drwgs AFC |  | 229d | 2009-11-24 A | 2010-10-20 A | EC45311005 FF+20d | 100% |  | EC603110 | EC603110 | 87A | 31 | 999 | 200 | E | E | C | EC60 | 3110 | de | LND | LNK | 3101C96 |  | 200 |  |  |  |
| EC45311010 |  | CA31 SiloStruc - Building Layout drwgs IFC | milestone | 0d | 2010-04-15 A | 2010-04-15 A | EC45311005 FF-15d | 100% |  | EC45311010 | EC45311010 | 87A | 31 | 999 | 200 | E | E | C | EC45 | 3110 | ar | LND | LNK |  |  |  |  |  |  |
| EC45311015 |  | CA31 SiloStruc - Review Building Layout drwgs |  | 10d | 2010-04-15 A | 2010-04-28 A | EC45311010 | 100% |  | EC45311015 | EC45311015 | 87A | 31 |  | 200 | E | E | C | EC45 | 3110 | ar | LND | LND |  |  |  |  |  |  |
|  | N | **N Structural Steel** |  |  | 2008-03-03 | 2011-01-07 |  |  |  |  |  |  |  |  |  |  |  |  |  |  |  |  |  |  |  |  |  |  |  |
| EN153110 |  | CA31 SiloStruc SK3101-CAD Model/Concepts StrStee |  | 126d | 2008-03-03 A | 2008-08-29 A | AD2230 FF-40d | 100% |  | EN153110 | EN153110 | 87B | 31 | N02Y | 200 | E | E | N | EN15 | 3110 | de | LND | LND |  | 0 | 200 | N02Y | 055 |  |
| EN21311005 |  | CA31 SiloStruc SK3101 - GA-Drwgs + Fdtn Loads |  | 80d | 2009-01-26 A | 2009-05-20 A | EE46311005, ER163110, AD2230 FS+20d, EH05311008, EJ46311005, EN153110 | 100% |  | EN21311005 | EN21311005 | 87B | 31 | N02Y | 200 |  | E | N | EN21 | 3110 | de | LND | LND |  |  |  | N02Y |  |  |
| EN24311005 |  | CA31 SiloStruc SK3101 - Static Calc f.Fdtn Loads |  | 15d | 2009-06-02 A | 2009-06-22 A | EN21311005 | 100% |  | EN24311005 | EN24311005 | 87B | 31 | N02Y | 200 |  | E | N | EN24 | 3110 | de | LND | LND |  |  |  | N02Y |  |  |
| EN253110 |  | CA31 SiloStruc SK3101 - Loads for Civil | milestone | 0d | 2009-06-22 A | 2009-06-22 A | EN24311005 FS-1d | 100% |  | EN253110 | EN253110 | 87B | 31 | N02Y | 200 | E | E | N | EN25 | 3110 | de | LND | LND |  | 0 | 200 | N02Y | 055 |  |
| EN21311010 |  | CA31 SiloStruc SK3101 - GA-Drwgs + Final Loads |  | 20d | 2009-10-12 A | 2009-11-06 A | EB053110 FS-5d, EN21311005, EJ46311008 FF+5d, EM053110 FS-5d, EE46311008, EN24311005 FS+5d, EN253110 SS-8d | 100% | TKB-S [2880 h] | EN21311010 | EN21311010 | 87B | 31 | N02Y | 200 |  | E | N | EN21 | 3110 | de | LND | LND |  |  |  | N02Y |  | 2880,00 |
| EN24311010 |  | CA31 SiloStruc SK3101 - Final Static Calc |  | 100d | 2009-11-09 A | 2010-04-06 A | EN21311010 | 100% |  | EN24311010 | EN24311010 | 87B | 31 | N02Y | 200 |  | E | N | EN24 | 3110 | de | LND | LNK |  |  |  | N02Y |  |  |
| EN263110 |  | CA31 SiloStruc SK3101 - Layout dwgs input KM dwg |  | 74d | 2010-01-04 A | 2010-04-19 A | F4035 FF+20d, EN24311010 FF+9d | 100% | TKB-S [2400 h] | EN263110 | EN263110 | 87B | 31 | N02Y | 200 |  | E | N | EN26 | 3110 | st | LND | LND |  |  |  | N02Y |  | 2400,00 |
| EN803110 |  | CA31 SiloStruc - Cladding Drwgs |  | 217d | 2010-03-02 A | 2011-01-07 A | ER393110 FF+10d, HEN80 SS | 100% |  | EN803110 | EN803110 | 87B | 31 | N02Y | 200 | E | E | N | EN80 | 3110 | de | LND | LNK | 3101C61 |  | 200 | N02Y |  |  |
| EN673110 |  | CA31 SiloStruc SK3101 - Grating Cut-Out drwgs |  | 19d | 2010-05-25 A | 2010-06-18 A | F9250, EN263110 FF+10d, ER423110 FF, EN263100 FF | 100% | TKB-S [960 h] | EN673110 | EN673110 | 87B | 31 | N02Y | 200 | C | E | N | EN67 | 3110 | de | LND | LND |  |  | 200 | N02Y |  | 960,00 |
| EN27311005 |  | CA31 SiloStruc SK3101 - KM drwgs Structure |  | 50d | 2010-06-28 A | 2010-09-03 A | EN24311005, EN263110 FS+10d, P3N01D FS+1d | 100% | KM Drwgs preparation by Cheljabinsk [679 t] | EN27311005 | EN27311005 | 87B | 31 | N02Y | 200 |  | E | N | EN27 | 3110 | de | LND | Chel |  |  |  | N02Y |  | 0,00 |
| EN27311015 |  | CA31 SiloStruc SK3101 - KM drwgs Cladding |  | 82d | 2010-06-28 A | 2010-10-19 A | EN263110 FS+20d | 100% |  | EN27311015 | EN27311015 | 87B | 31 | N02Y | 200 |  | E | N | EN80 | 3110 | de | LND | Chel |  |  |  | N02Y |  |  |
| EN27311025 |  | CA31 SiloStruc SK3101 - KM drwgs Auxiliary Structures |  | 87d | 2010-06-28 A | 2010-10-26 A | P3N01D FS+20d, EN263110 | 100% |  | EN27311025 | EN27311025 | 87B | 31 | N02Y | 200 |  | E | N | EN27 | 3110 | de | LND | Chel |  |  |  | N02Y |  |  |
| EN643110 |  | CA31 SiloStruc SK3101 - Check Grating Cut-Out drwgs |  | 10d | 2010-07-01 A | 2010-07-14 A | EN673110 | 100% |  | EN643110 | EN643110 | 87B | 31 | N02Y | 200 | C | E | N | EN67 | 3110 | de | LND | LND |  |  | 200 | N02Y |  |  |
| EN27311010 |  | CA31 SiloStruc SK3101 - Check KM drwgs Structure |  | 30d | 2010-09-06 A | 2010-10-15 A | EN27311005 | 100% |  | EN27311010 | EN27311010 | 87B | 31 | N02Y | 200 |  | E | N | EN27 | 3110 | de | LND | LND |  |  |  | N02Y |  |  |
| EN27311020 |  | CA31 SiloStruc SK3101 - Check KM drwgs Cladding |  | 10d | 2010-10-20 A | 2010-11-02 A | EN27311015 | 100% |  | EN27311020 | EN27311020 | 87B | 31 | N02Y | 200 |  | E | N | EN27 | 3110 | de | LND | LND |  |  |  | N02Y |  |  |
| EN283110 |  | CA31 SiloStruc SK3101 - Shop dwgs(KMD) by Vendor |  | 37d | 2010-10-28 A | 2010-12-20 A | EN27311020 FF+10d, EN273111030 FF, EN27311010 FS+14d | 100% |  | EN283110 | EN283110 | 87B | 31 | N02Y | 200 |  | E | N | EN28 | 3110 | de | LND | Chel |  |  |  | N02Y |  |  |
| EN273111030 |  | CA31 SiloStruc SK3101 - Check KM drwgs Auxiliary Structures |  | 10d | 2010-11-01 A | 2010-11-12 A | EN27311025 | 100% |  | EN273111030 | EN273111030 | 87B | 31 | N02Y | 200 |  | E | N | EN27 | 3110 | de | LND | LND |  |  |  | N02Y |  |  |
| EN683110 |  | CA31 SiloStruc SK3101 - Grating Fabrication drwgs |  | 20d | 2010-11-11 A | 2010-12-09 A | EN283110 SS+10d, EN673110, EN643110 | 100% |  | EN683110 | EN683110 | 87B | 31 | N02Y | 200 | C | E | N | EN68 | 3110 | de | LND | Chel |  |  | 200 | N02Y |  |  |

Notes:
- EC423110: P3 Activity Log Info: fixed Layout
- EC443110: P3 Activity Log Info: incl. PMT approval
- EC223110: P3 Activity Log Info: TKB-B Keyplan to Subcontractor
- EC45311005: P3 Activity Log Info: incl. PMT approval
- EC133100: P3 Activity Log Info: fixed Layout
- EC45311010: P3 Activity Log Info: incl. PMT / approval
- EC45311015: P3 Activity Log Info: incl. PMT approval

| ID | WBS | Activity | Type | Duration | Start | Finish | Predecessors | Complete | Resources | UDF_SAVE ACTID | UDF_SAVE ACT ID | Department | Constr. Area | Inquiry/Order No | PMT-Respons. | WBS Phase | WBS Discipline | WBS Type of Work | WBS Objects | IMS | UPT | PMT-Area | PMT-Schedule Org | PMT-Discipline | PMT-Phase | TB26 Ressource Budget | Pro Unit/DocCode | Type of Work |
| --- | --- | --- | --- | --- | --- | --- | --- | --- | --- | --- | --- | --- | --- | --- | --- | --- | --- | --- | --- | --- | --- | --- | --- | --- | --- | --- | --- | --- |
|  | H | **H HVAC** |  |  | 2008-10-06 | 2010-10-28 |  |  |  |  |  |  |  |  |  |  |  |  |  |  |  |  |  |  |  |  |  |  |
| EH05311008 |  | CA31 SiloStruc - prel Loads for Civil Struc |  | 15d | 2008-10-06 A | 2008-10-24 A | F4120 | 100% |  | EH05311008 | EH05311008 | 87C | 31 | 999 | LND | E | H | EH11 | 3110 | OTH | LND |  |  |  |  |  |  |  |
| EH203110 |  | CA31 SiloStruc - HVAC&Plumbing / Feed/Basic |  | 175d | 2008-10-06 A | 2009-06-23 A | AD2230 FF+20d | 100% |  | EH203110 | EH203110 | 87C | 31 | 999 | LND | E | H | EH20 | 3110 | OTH | LND | 200 | 200 | 035 | E |  |  |  |
| EH30311005 |  | CA31 SiloStruc - HVAC Layouts Dwgs AFC |  | 280d | 2009-09-14 A | 2010-10-21 A | EH203110, EH30314005 SS+10d | 100% | TKB-H [480 h] | EH30311005 | EH30311005 | 87C | 31 |  | LNK | E | H | EH30 | 3110 | OTH | LND | 200 | 200 | 035 | E | 480,00 | 3101H23 |  |
| EH40311005 |  | CA31 SiloStruc - HVAC Calculations&Flow Diagrams |  | 280d | 2009-09-14 A | 2010-10-21 A | EH30311005 SS | 100% | TKB-H [320 h] | EH40311005 | EH40311005 | 87C | 31 |  | LNK | E | H | EH40 | 3110 | OTH | LND | 200 | 200 | 035 | E | 320,00 | 3101H22 |  |
| EH073110 |  | CA31 SiloStruc - Issue of Dwgs&Doc's by RDI | level of effort | 215d | 2009-12-15 A | 2010-10-21 A | EH30311005 FF, EH30311005 SS+65d, EH40311010 FF | 100% | TKB-H [5336 h] | EH073110 | EH073110 | 87C | 31 |  | LNK | E | H | EH30 | 3110 | OTH | LND | 200 | 200 | 035 | E | 5336,00 |  |  |
| EH30311010 |  | CA31 SiloStruc - HVAC Layouts Dwgs IFC | milestone | 0d | 2010-04-15 A | 2010-04-15 A | EH30311005 FF-20d | 100% |  | EH30311010 | EH30311010 | 87C | 31 |  | LNK | E | H | EH30 | 3110 | OTH | LND | 200 | 200 | 035 | E |  |  |  |
| EH40311010 |  | CA31 SiloStruc - HVAC Calc./Diagrams IFC | milestone | 0d | 2010-04-15 A | 2010-04-15 A | EH40311005 FF-19d | 100% |  | EH40311010 | EH40311010 | 87C | 31 |  | LNK | E | H | EH40 | 3110 | OTH | LND | 200 | 200 | 035 | E |  |  |  |
| EH30311015 |  | CA31 SiloStruc - Review HVAC Layout Dwgs |  | 139d | 2010-04-15 A | 2010-10-28 A | EH30311010 | 100% | TKB-H [480 h] | EH30311015 | EH30311015 | 87C | 31 |  | LND | E | H | EH30 | 3110 | OTH | LND | 200 | 200 | 035 | E | 480,00 |  |  |
| EH053110 |  | CA31 SiloStruc - Final Loads f.Civil/StrSteel | milestone | 0d | 2010-10-21 A | 2010-10-21 A | E3H0150 SF, EH30311005 FF | 100% |  | EH053110 | EH053110 | 87C | 31 | 999 | LNK | E | H | EH12 | 3110 | OTH | LND | 200 |  |  |  |  |  |  |
| EH243110 |  | CA31 SiloStruc - Wall & Floor open.details | milestone | 0d | 2010-10-21 A | 2010-10-21 A | E3H0150 SF, EH053110 FF | 100% |  | EH243110 | EH243110 | 87C | 31 | 999 | LNK | E | H | EH24 | 3110 | OTH | LND | 200 | 200 | 035 | E |  | 3101H21 |  |
|  | B | **B Mechanical - Stationary Equipment** |  |  | 2009-08-03 | 2009-08-03 |  |  |  |  |  |  |  |  |  |  |  |  |  |  |  |  |  |  |  |  |  |  |
| EB053110 |  | CA31 SiloStruc - Final Loads for Struc Steel | milestone | 0d | 2009-08-03 A | 2009-08-03 A | E3ALL440, E3U0610 FF | 100% |  | EB053110 | EB053110 | 869 | 31 | 999 | LND | E | B | EB05 | 3110 | 3 | LND | 200 |  |  |  |  |  |  |
|  | M | **M Mechanical - Rotating Equipment** |  |  | 2009-08-03 | 2009-08-03 |  |  |  |  |  |  |  |  |  |  |  |  |  |  |  |  |  |  |  |  |  |  |
| EM053110 |  | CA31 SiloStruc - Final Loads for Struc Steel | milestone | 0d | 2009-08-03 A | 2009-08-03 A | E3U0610 FF | 100% |  | EM053110 | EM053110 | 867 | 31 | 999 | LND | E | M | EM05 | 3110 | I | LND | 200 |  |  |  |  |  |  |
|  | R | **R Piping** |  |  | 2008-04-01 | 2011-01-14 |  |  |  |  |  |  |  |  |  |  |  |  |  |  |  |  |  |  |  |  |  |  |
| ER153110 |  | CA31 SiloStruc - Conceptual Piping |  | 169d | 2008-04-01 A | 2008-11-28 A | F2760 | 100% |  | ER153110 | ER153110 | 876 | 31 | 999 | LNZ | E | R | ER15 | 3110 | PL | LND | 200 |  |  |  |  |  |  |
| ER303110 |  | CA31 SiloStruc - CAD Model Piping / Eqpt |  | 489d | 2008-07-01 A | 2010-06-15 A | ER153110 SS, ER393110 FF+15d | 100% |  | ER303110 | ER303110 | 876 | 31 | 2DC8990 | LND | E | R | ER30 | 3110 | PL | LND | 200 |  |  |  |  |  |  |
| ER163110 |  | CA31 SiloStruc - prel Loads for Steel Struc |  | 14d | 2008-09-22 A | 2008-10-10 A | ER153110 FF | 100% |  | ER163110 | ER163110 | 876 | 31 | 999 | LNZ | E | R | ER16 | 3110 | PL | LND | 200 |  |  |  |  |  |  |
| ER363110 |  | CA31 SiloStruc - CAD Model Review 60% |  | 10d | 2009-10-14 A | 2009-10-27 A | F4035 FF | 100% |  | ER363110 | ER363110 | 876 | 31 | 2DC8990 | LND | E | R | ER36 | 3110 | 2 | LND | 200 |  |  |  |  |  |  |
| ER193110 |  | CA31 SiloStruc - Final Loads for Steel Struc | milestone | 0d | 2009-11-10 A | 2009-11-10 A | EN21311010 FF, ER163110 FF, F4035 FF+10d | 100% |  | ER193110 | ER193110 | 876 | 31 | 999 | LND | E | R | ER19 | 3110 | PL | LND | 200 |  |  |  |  |  |  |
| ER423110 |  | CA31 SiloStruc - Stress Calculation |  | 60d | 2009-11-16 A | 2010-02-12 A | ER363110 | 100% |  | ER423110 | ER423110 | 872 | 31 | 2DC8990 | LND | E | R | ER42 | 3110 | PL | LND | 200 |  |  |  |  |  |  |
| ER393110 |  | CA31 SiloStruc - CAD Model Review 90% |  | 10d | 2010-04-26 A | 2010-05-07 A | F9250 SS | 100% |  | ER393110 | ER393110 | 876 | 31 | 2DC8990 | LND | E | R | ER39 | 3110 | 3 | LND | 200 |  |  |  |  |  | PU10 |
| ER453110 |  | CA31 SiloStruc - Piping Isometrics |  | 147d | 2010-05-26 A | 2010-12-17 A | A1KL0025, ER303110 FF+10d, ER393130 FS+10d, ER423110, ER363110 | 100% |  | ER453110 | ER453110 | 876 | 31 | 2DC8990 | LND | E | R | ER45 | 3110 | 5 | LND | 200 |  |  |  |  |  | PU10 |
| ER45311005 |  | CA31 SiloStruc - Piping Isometrics (ZEP) |  | 147d | 2010-05-26 A | 2010-12-17 A | ER303110 FF+10d, ER363110, ER423110, ER393130 FS+10d | 100% |  | ER45311005 | ER45311005 | 876 | 31 | 2DC8990 | ZEP | E | R | ER45 | 3110 | 5 | LND | 200 |  |  |  |  |  | PU10 |
| ER493110 |  | CA31 SiloStruc - Design Check/ Rel.Isos&BOM |  | 125d | 2010-07-21 A | 2011-01-14 A | ER45311005 SS+40d, ER453110 SS+40d | 100% |  | ER493110 | ER493110 | 876 | 31 | 2DC8990 | LND | E | R | ER49 | 3110 | 5 | LND | 200 |  |  |  |  |  |  |
| ER49311005 |  | CA31 SiloStruc - Design Check/Rel.Isos&BOM ZEP |  | 125d | 2010-07-21 A | 2011-01-14 A | ER45311005 SS+40d, ER453110 SS+40d | 100% |  | ER49311005 | ER49311005 | 876 | 31 | 2DC8990 | ZEP | E | R | ER49 | 3110 | 5 | LND | 200 |  |  |  |  |  |  |
| ER443110 |  | CA31 SiloStruc - Piping Isometrics (UG) |  | 31d | 2010-09-24 A | 2010-11-05 A | ER440000 SS, EC303110 SS | 100% |  | ER443110 | ER443110 | 876 | 31 | 999 | LND | E | R | ER44 | 3110 | 4 | LND | 200 | 200 |  | E |  |  |  |

| ID | WBS | Activity | Type | Duration | Start | Finish | Predecessors | Complete | Resources | UDF_SAVE ACTID | UDF_SAVE ACT ID | Department | Constr. Area | Inquiry/Order No | PMT-Phase | PMT-Respons. | WBS Phase | WBS Discipline | WBS Type of Work | WBS Objects | IMS | UPT | Pro Unit/DocCode | TB26 Ressource Budget | PMT-Area | PMT-Schedule Org | Zeigen/n. Zeigen | Type of Work |
| --- | --- | --- | --- | --- | --- | --- | --- | --- | --- | --- | --- | --- | --- | --- | --- | --- | --- | --- | --- | --- | --- | --- | --- | --- | --- | --- | --- | --- |
|  | E | **E Electrical** |  |  | 2008-10-06 | 2010-12-17 |  |  |  |  |  |  |  |  |  |  |  |  |  |  |  |  |  |  |  |  |  |  |
| EE46311005 |  | CA31 SiloStruc - prelimLoads f.Civil / StrSteel |  | 10d | 2008-10-06 A | 2008-10-17 A | F3060 FF | 100% |  | EE46311005 | EE46311005 | 874 | 31 | 999 | E | LND | E | E | EE11 | 3110 | E | LND |  |  |  |  |  |  |
| EE903110 |  | CA31 SiloStruc - Earthing Details |  | 30d | 2009-02-23 A | 2009-04-03 A | AD2230 FS+40d | 100% |  | EE903110 | EE903110 | 874 | 31 | 999 | E | LND | E | E | EE90 | 3110 | E | LND |  |  |  |  |  |  |
| EE46311008 |  | CA31 SiloStruc - Final Loads f.Civil / StrSteel |  | 20d | 2009-09-14 A | 2009-10-09 A | EE46311005 | 100% |  | EE46311008 | EE46311008 | 874 | 31 | 999 | E | LND | E | E | EE12 | 3110 | E | LND |  |  |  |  |  |  |
| EE46311010 |  | CA31 SiloStruc - El. CableTray Layout Pl. / LOP's 1st Issue |  | 104d | 2009-12-07 A | 2010-05-07 A | EE460000, F4035 FS+80d | 100% |  | EE46311010 | EE46311010 | 874 | 31 | 999 | E | LND | E | E | EE46 | 3110 | E | LND |  |  |  |  |  |  |
| EE563110 |  | CA31 SiloStruc - Cable Pulling Details |  | 119d | 2009-12-10 A | 2010-06-04 A | EE500130, EE46311010 FF | 100% |  | EE563110 | EE563110 | 874 | 31 | 999 | E | LND | E | E | EE56 | 3110 | E | LND |  |  |  |  |  |  |
| EE763110 |  | CA31 SiloStruc - Layout Plan Light.& Sockets 1st Issue |  | 229d | 2010-01-26 A | 2010-12-17 A | EE000180, EC503110 SF+10d | 100% |  | EE763110 | EE763110 | 874 | 31 | 999 | E | LNK | E | E | EE76 | 3110 | E | LND |  |  |  |  |  |  |
|  | J | **J Instrumentation** |  |  | 2008-10-06 | 2011-02-21 |  |  |  |  |  |  |  |  |  |  |  |  |  |  |  |  |  |  |  |  |  |  |
| EJ46311005 |  | CA31 SiloStruc - prelimLoads f.Civil / StrSteel |  | 10d | 2008-10-06 A | 2008-10-17 A | F3060 FF | 100% |  | EJ46311005 | EJ46311005 | 86E | 31 | 999 | E | LND | E | J | EJ11 | 3110 | I | LND | 999 |  |  |  |  |  |
| EJ46311008 |  | CA31 SiloStruc - Final Loads f.Civil / StrSteel |  | 10d | 2009-10-19 A | 2009-10-30 A | EJ46311005 | 100% |  | EJ46311008 | EJ46311008 | 86E | 31 | 999 | E | LND | E | J | EJ12 | 3110 | I | LND | 999 |  |  |  |  |  |
| EJ360000 |  | General - Hook-Up drwgs (revised / final version) | level of effort | 279d | 2010-01-18 A | 2011-02-21 A | EJ363120 SS, EJ363110 SS | 100% | TAP [7680 h] | EJ360000 | EJ360000 | 86E | 31 | 999 | C | LEI | E | J | EJ36 | 3110 | I | LND | 999 | 7680,00 | 200 | 200 |  |  |
| EJ363110 |  | CA31 SiloStruc - Hook-Up drwgs 1st Issue |  | 100d | 2010-01-18 A | 2010-06-10 A | F4035 FS+50d, A1EJ0080 | 100% |  | EJ363110 | EJ363110 | 86E | 31 | 999 | C | LEI | E | J | EJ36 | 3110 | I | LND | 999 |  | 200 | 200 |  |  |
| EJ46311010 |  | CA31 SiloStruc - Instr Cable Tray Layout Plans 1st Issue |  | 48d | 2010-03-01 A | 2010-05-07 A | F4035 FF+65d, F9250 FS+10d, EE46311010 FF | 100% | TAP [1600 h] | EJ46311010 | EJ46311010 | 86E | 31 | 999 | E | LEI | E | J | EJ41 | 3110 | I | LND | 999 | 1600,00 |  |  |  |  |
| EJ323110 |  | CA31 SiloStruc - JB Location drwgs |  | 122d | 2010-05-26 A | 2010-11-11 A | F4035, F9250 FF+35d | 100% | TAP [2560 h] | EJ323110 | EJ323110 | 86E | 31 | 999 | C | ZEP | E | J | EJ37 | 3110 | I | LND | 999 | 2560,00 | 200 | 200 |  |  |
| EJ803110 |  | CA31 SiloStruc - Loop Diagrams |  | 70d | 2010-08-20 A | 2010-11-26 A | A1EJ0040 SF, EJ800010 | 100% |  | EJ803110 | EJ803110 | 86E | 31 | 999 | E | LEI | E | J | EJ80 | 3110 | I | LND | 999 |  |  |  |  |  |
|  | 3115 | **3115 Conveying Tower - CA31** |  |  | 2009-06-08 | 2010-12-27 |  |  |  |  |  |  |  |  |  |  |  |  |  |  |  |  |  |  |  |  |  |  |
|  | C | **C Civil** |  |  | 2009-06-08 | 2010-03-19 |  |  |  |  |  |  |  |  |  |  |  |  |  |  |  |  |  |  |  |  |  |  |
| EC243115 |  | CA31 ConveyingTower - Layout drwgs / Loads IFD |  | 34d | 2009-06-08 A | 2009-07-24 A | EC443110 FF | 100% |  | EC243115 | EC243115 | 87A | 31 | 999 |  | LND | E | C | EC44 | 3115 | de | LND | 3105C01 |  | 200 |  |  |  |
| EC263115 |  | CA31 ConveyingTower - Civil Static Calculation Found. |  | 88d | 2009-09-14 A | 2010-01-20 A | P3C00D FS+20d, EC243115 | 100% |  | EC263115 | EC263115 | 87A | 31 | 999 |  | LNK | E | C | EC46 | 3115 | de | LND | 3105C14 |  | 200 |  | C1 |  |
| EC283115 |  | CA31 ConveyingTower - Formw/Reinf drwgs Found./Base Plate |  | 125d | 2009-09-21 A | 2010-03-19 A | EC263115 FF | 100% |  | EC283115 | EC283115 | 87A | 31 | 999 | E | LNK | E | C | EC48 | 3115 | ar | LND | 3105C21 |  | 200 | 200 |  |  |
| EC45311515 |  | CA31 ConveyingTower - Review Building Layout drwgs |  | 10d | 2010-02-01 A | 2010-02-12 A | EC283115 | 100% |  | EC45311515 | EC45311515 | 87A | 31 |  | E | LND | E | C | EC45 | 3115 | ar | LND |  |  | 200 |  |  |  |
|  | N | **N Structural Steel** |  |  | 2009-11-09 | 2010-12-27 |  |  |  |  |  |  |  |  |  |  |  |  |  |  |  |  |  |  |  |  |  |  |
| EN21311510 |  | CA31 Staircase SK3105 - GA-Drwgs + Final Loads |  | 16d | 2009-11-09 A | 2009-12-01 A | EN21311010 SS+20d | 100% | TKB-S [2880 h] | EN21311510 | EN21311510 | 87B | 31 | N02# |  | LND | E | N | EN21 | 3115 | de | LND |  | 2880,00 | 200 |  |  | N02# |
| EN24311510 |  | CA31 Staircase SK3105 - Final Static Calc |  | 87d | 2009-12-02 A | 2010-04-09 A | EN21311510 | 100% |  | EN24311510 | EN24311510 | 87B | 31 | N02# |  | LNK | E | N | EN24 | 3115 | de | LND |  |  | 200 |  |  | N02# |
| EN263115 |  | CA31 Staircase SK3105 - Layout dwgs input KM dwg |  | 71d | 2010-01-12 A | 2010-04-22 A | EN24311510 FF+9d, F4035 FF+20d | 100% | TKB-S [2400 h] | EN263115 | EN263115 | 87B | 31 | N02# |  | LND | E | N | EN26 | 3115 | st | LND |  | 2400,00 | 200 |  |  | N02# |
| EN803115 |  | CA31 SiloStaircase - Cladding Drwgs |  | 83d | 2010-03-17 A | 2010-07-15 A | EN803110 SS, EC283115, ER393110 FF+24d | 100% |  | EN803115 | EN803115 | 87B | 31 | N02# | E | LNK | E | N | EN80 | 3115 | de | LND | 3105C61 |  | 200 | 200 |  | N02# |
| EN673115 |  | CA31 Staircase SK3105 - Grating Cut-Out drwgs |  | 19d | 2010-05-25 A | 2010-06-18 A | F9250, EN263115 FF+10d | 100% | TKB-S [1280 h] | EN673115 | EN673115 | 87B | 31 | N02# | C | LND | E | N | EN67 | 3115 | de | LND |  | 1280,00 | 200 | 200 |  | N02# |
| EN27311505 |  | CA31 Staircase SK3105 - KM drwgs |  | 98d | 2010-06-29 A | 2010-11-11 A | P3N01D FS+1d, EN263115 | 100% | KM Drwgs preparation by Cheljabinsk [169 t] | EN27311505 | EN27311505 | 87B | 31 | N02# |  | Chel | E | N | EN27 | 3115 | de | LND |  | 0,00 | 200 |  |  | N02# |
| EN643115 |  | CA31 Staircase SK3105 - Check Grating Cut-Out drwgs |  | 10d | 2010-07-01 A | 2010-07-14 A | EN673115 | 100% |  | EN643115 | EN643115 | 87B | 31 | N02# | C | LND | E | N | EN67 | 3115 | de | LND |  |  | 200 | 200 |  | N02# |
| EN27311510 |  | CA31 Staircase SK3105 - Check KM drwgs |  | 5d | 2010-11-12 A | 2010-11-19 A | EN27311505 | 100% |  | EN27311510 | EN27311510 | 87B | 31 | N02# |  | LND | E | N | EN27 | 3115 | de | LND |  |  | 200 |  |  | N02# |
| EN283115 |  | CA31 Staircase SK3105 - Shop dwgs(KMD) by Vendor |  | 25d | 2010-11-22 A | 2010-12-27 A | EN27311510 | 100% |  | EN283115 | EN283115 | 87B | 31 | N02# |  | Chel | E | N | EN28 | 3115 | de | LND |  |  | 200 |  |  | N02# |
| EN683115 |  | CA31 Staircase SK3105 - Grating Fabrication drwgs |  | 25d | 2010-11-22 A | 2010-12-27 A | EN643115, EN673115, EN283115 SS | 100% |  | EN683115 | EN683115 | 87B | 31 | N02# | C | Chel | E | N | EN68 | 3115 | de | LND |  |  | 200 | 200 |  | N02# |

Notes:
- EC243115: P3 Activity Log Info: incl. PMT approval
- EC45311515: P3 Activity Log Info: incl. PMT approval

| ID | WBS | Activity | Type | Duration | Start | Finish | Predecessors | Complete | Resources | UDF_SAVE ACTID | UDF_SAVE ACT ID | Department | Constr. Area | Inquiry/Order No | PMT-Area | PMT-Phase | WBS Phase | WBS Discipline | WBS Type of Work | WBS Objects | IMS | UPT | PMT-Respons. | Pro Unit/DocCode | Zeigen/n. Zeigen | PMT-Schedule Org | Type of Work | PMT-Discipline | TB26 Ressource Budget |
| --- | --- | --- | --- | --- | --- | --- | --- | --- | --- | --- | --- | --- | --- | --- | --- | --- | --- | --- | --- | --- | --- | --- | --- | --- | --- | --- | --- | --- | --- |
|  | 3120 | **3120 Blower Room & Truck Inliner Loading - CA31** |  |  | 2008-03-03 | 2011-04-25 |  |  |  |  |  |  |  |  |  |  |  |  |  |  |  |  |  |  |  |  |  |  |  |
|  | 0B | **0B General Activities** |  |  | 2009-01-03 | 2009-01-03 |  |  |  |  |  |  |  |  |  |  |  |  |  |  |  |  |  |  |  |  |  |  |  |
| E0203120 |  | CA31 Blower Sec - freeze constr. concept | milestone | 0d | 2009-01-03 A | 2009-01-03 A | F3600 | 100% |  | E0203120 | E0203120 | 87A | 31 | 999 | 200 | E | E | 0B | E020 | 3120 | INS | LND |  |  |  |  |  |  |  |
|  | C | **C Civil** |  |  | 2008-03-03 | 2011-04-25 |  |  |  |  |  |  |  |  |  |  |  |  |  |  |  |  |  |  |  |  |  |  |  |
| EC423120 |  | CA31 Blower Sec - Building Concept |  | 171d | 2008-03-03 A | 2008-11-04 A | F2760 | 100% |  | EC423120 | EC423120 | 87A | 31 | 999 | 200 |  | E | C | EC42 | 3120 | cq | LND | LND |  |  |  |  |  |  |
| EC243120 |  | CA31 Blower Sec - Fdtn Data Sheets ComprFdtn |  | 20d | 2009-01-02 A | 2009-01-29 A | E3U1040 FF, ER163120 | 100% |  | EC243120 | EC243120 | 87A | 31 | 999 | 200 |  | E | C | EC24 | 3120 | de | LND | LND | 3111C01 |  |  |  |  |  |
| EC443120 |  | CA31 Blower Sec - Building Layout drwgs IFD |  | 43d | 2009-05-26 A | 2009-07-24 A | EC423120, E0203120, AD2230 FF+30d, EC221320 FF, EC243120 FF, EC60310010 FF, EC60310002 FF, EC443100 FF | 100% |  | EC443120 | EC443120 | 87A | 31 | 999 | 200 |  | E | C | EC44 | 3120 | cq | LND | LND | 3104C01 |  |  |  |  |  |
| EC221320 |  | CA31 Blower Sec - Civil Foundation Loads |  | 20d | 2009-06-10 A | 2009-07-07 A | ER163120, EN253120 | 100% |  | EC221320 | EC221320 | 87A | 31 | 999 | 200 |  | E | C | EC22 | 3120 | de | LND | LND |  |  |  |  |  |  |
| EC463120 |  | CA31 Blower Sec - Civil Static Calc Bldg |  | 199d | 2009-09-14 A | 2010-06-30 A | P3C00D FS+20d, EC463140 SS+5d, EC443120 | 100% |  | EC463120 | EC463120 | 87A | 31 | 999 | 200 |  | E | C | EC46 | 3120 | de | LND | LNK | 3104C14 | C1 |  |  |  |  |
| EC153120 |  | CA31 Blower Sec - Piling drwgs AFC |  | 35d | 2009-09-21 A | 2009-11-06 A | EC463120 SS+5d, EC15000010 | 100% |  | EC153120 | EC153120 | 87A | 31 | 999 | 200 |  | E | C | EC15 | 3120 | PI | LND | LNK | 3104C16 | C1 |  |  |  |  |
| EC45312005 |  | CA31 Blower Sec - Building Layout drwgs AFC |  | 251d | 2009-09-28 A | 2010-09-24 A | EC463120 SS+10d, AD2230, P3C00D FS+10d, EC443120, EC48100 | 100% |  | EC45312005 | EC45312005 | 87A | 31 | 999 | 200 | E | E | C | EC45 | 3120 | ar | LND | LNK | 3104C13 |  |  |  |  |  |
| EC48312003 |  | CA31 BlowerSec - Formw/Reinf drwgs Found. AFC |  | 110d | 2009-10-19 A | 2010-03-26 A | EC463120 SS+20d, EC153120 SS+20d | 100% |  | EC48312003 | EC48312003 | 87A | 31 | 999 | 200 | E | E | C | EC48 | 3120 | ar | LND | LNK | 3104C21 |  | 200 |  |  |  |
| EC48312004 |  | CA31 BlowerSec - Precast Layout drwgs AFC |  | 186d | 2009-10-26 A | 2010-07-23 A | EC463120 SS+20d, EC48312003 SS+5d | 100% |  | EC48312004 | EC48312004 | 87A | 31 | 999 | 200 | E | E | C | EC48 | 3120 | PRE | LND | LNK | 3104C31 | C7 | 200 |  |  |  |
| EC48312006 |  | CA31 BlowerSec - Precast Formw/Reinf. drwgs AFC <7,20m |  | 186d | 2009-10-26 A | 2010-07-23 A | EC48312004 SS | 100% |  | EC48312006 | EC48312006 | 87A | 31 | 999 | 200 | E | E | C | EC48 | 3120 | ar | LND | LNK | 3104C53 | C7 | 200 |  |  |  |
| EC48312005 |  | CA31 BlowerSec - Formw/Reinf drwgs GF +0,00m AFC |  | 100d | 2009-11-02 A | 2010-03-26 A | EC463120 SS+35d, EC153120 FF+25d | 100% |  | EC48312005 | EC48312005 | 87A | 31 | 999 | 200 | E | E | C | EC48 | 3120 | ar | LND | LNK | 3104C22 |  | 200 |  |  |  |
| EC48312008 |  | CA31 BlowerSec - Precast Formw/Reinf. drwgs AFC <13,80m |  | 196d | 2009-11-09 A | 2010-08-20 A | EC48312006 FF | 100% |  | EC48312008 | EC48312008 | 87A | 31 | 999 | 200 | E | E | C | EC48 | 3120 | ar | LND | LNK | 3104C54 | C7 | 200 |  |  |  |
| EC48312010 |  | CA31 BlowerSec - Formw/Reinf drwgs Struc +7,20m AFC |  | 206d | 2009-11-16 A | 2010-09-10 A | EC48312005 FF+30d | 100% |  | EC48312010 | EC48312010 | 87A | 31 | 999 | 200 | E | E | C | EC48 | 3120 | ar | LND | LNK | 3104C23 |  | 200 |  |  |  |
| EC48312015 |  | CA31 BlowerSec - Formw/Reinf drwgs Roof +13,80m AFC |  | 206d | 2009-11-16 A | 2010-09-10 A | EC48312010 FF | 100% |  | EC48312015 | EC48312015 | 87A | 31 | 999 | 200 | E | E | C | EC48 | 3120 | ar | LND | LNK | 3104C24 | C7 | 200 |  |  |  |
| EC45312015 |  | CA31 Blower Sec - Review Building Layout drwgs |  | 10d | 2009-12-08 A | 2009-12-21 A | EC45312010 | 100% |  | EC45312015 | EC45312015 | 87A | 31 |  | 200 | E | E | C | EC45 | 3120 | ar | LND | LND |  |  |  |  |  |  |
| EC503120 |  | CA31 Blower Sec - Architec Det.drwgs Bldg AFC |  | 349d | 2009-12-08 A | 2011-04-25 A | EC48312015 FF | 100% |  | EC503120 | EC503120 | 87A | 31 | 999 | 200 | E | E | C | EC50 | 3120 | ar | LND | LNK | 3104C41 |  | 200 |  |  |  |
| EC603120 |  | CA31 Blower Sec - Paving drwgs AFC |  | 204d | 2010-01-04 A | 2010-10-20 A | EC503120 SS+10d | 100% |  | EC603120 | EC603120 | 87A | 31 | 999 | 200 | E | E | C | EC60 | 3120 | de | LND | LNK | 3104C96 |  | 200 |  |  |  |
| EC45312010 |  | CA31 Blower Sec - Building Layout drwgs IFC | milestone | 0d | 2010-04-16 A | 2010-04-16 A | EC45312005 FF-20d | 100% |  | EC45312010 | EC45312010 | 87A | 31 | 999 | 200 | E | E | C | EC45 | 3120 | ar | LND | LNK |  |  |  |  |  |  |
|  | N | **N Structural Steel** |  |  | 2008-03-03 | 2011-03-03 |  |  |  |  |  |  |  |  |  |  |  |  |  |  |  |  |  |  |  |  |  |  |  |
| EN153120 |  | CA31 Blower Sec - CAD Model/Concepts StrSteel |  | 126d | 2008-03-03 A | 2008-08-29 A | AD2230 FF | 100% |  | EN153120 | EN153120 | 87B | 31 | N02Z | 200 | E | E | N | EN15 | 3120 | de | LND | LND |  | 0 | 200 | N02Z | 055 |  |
| EN21312005 |  | CA31 Blower Sec SK3104 - GA-Drwgs + Fdtn Loads |  | 77d | 2009-01-26 A | 2009-05-15 A | EE46312005, AD2230 FS+20d, EN153120 FF, EJ46312005 | 100% |  | EN21312005 | EN21312005 | 87B | 31 | N02Z | 200 |  | E | N | EN21 | 3120 | de | LND | LND |  |  |  | N02Z |  |  |
| EN24312005 |  | CA31 Blower Sec SK3104 - StaticCalc f.Fdtn Loads |  | 15d | 2009-05-18 A | 2009-06-09 A | EN21312005 | 100% |  | EN24312005 | EN24312005 | 87B | 31 | N02Z | 200 |  | E | N | EN24 | 3120 | de | LND | LND |  |  |  | N02Z |  |  |
| EN253120 |  | CA31 Blower Sec SK3104 - Loads for Civil | milestone | 0d | 2009-06-09 A | 2009-06-09 A | EN24312005 FF | 100% |  | EN253120 | EN253120 | 87B | 31 | N02Z | 200 | E | E | N | EN25 | 3120 | de | LND | LND |  | 0 | 200 | N02Z | 055 |  |
| EN21312010 |  | CA31 Blower Sec SK3104 - GA-Drwgs + Final Loads |  | 16d | 2009-11-23 A | 2009-12-14 A | EN21312005, EB053120, EJ46312008, EM053120, EE46312008 | 100% | TKB-S [192 h] | EN21312010 | EN21312010 | 87B | 31 | N02Z | 200 |  | E | N | EN21 | 3120 | de | LND | LND |  |  |  | N02Z |  | 192,00 |
| EN24312010 |  | CA31 Blower Sec SK3104 - Final Static Calc |  | 78d | 2009-12-15 A | 2010-04-09 A | EN21312010 | 100% |  | EN24312010 | EN24312010 | 87B | 31 | N02Z | 200 |  | E | N | EN24 | 3120 | de | LND | LNK |  |  |  | N02Z |  |  |
| EN263120 |  | CA31 Blower Sec SK3104 - Layout dwgs input for KM dwgs |  | 66d | 2010-01-27 A | 2010-04-30 A | F4035 FF+20d, EN24312010 FF+15d | 100% | TKB-S [240 h] | EN263120 | EN263120 | 87B | 31 | N02Z | 200 |  | E | N | EN26 | 3120 | st | LND | LND |  |  |  | N02Z |  | 240,00 |
| EN803120 |  | CA31 Blower Sec - KM drwgs Cladding |  | 178d | 2010-04-19 A | 2010-12-28 A | EN27312005 FF, ER393120 FF+19d | 100% |  | EN803120 | EN803120 | 87B | 31 | N02Z | 200 | E | E | N | EN80 | 3120 | de | LND | Chel | 3104C61 |  | 200 | N02Z |  |  |
| EN673120 |  | CA31 Blower Sec SK3104 - Grating Cut-Out drwgs |  | 13d | 2010-05-10 A | 2010-05-28 A | ER423120 FF, F9250 FF+10d | 100% | TKB-S [80 h] | EN673120 | EN673120 | 87B | 31 | N02Z | 200 | C | E | N | EN67 | 3120 | de | LND | LND |  |  | 200 | N02Z |  | 80,00 |
| EN27312005 |  | CA31 Blower Sec SK3104 - Roof Girders KM drwgs |  | 163d | 2010-05-10 A | 2010-12-28 A | EN263120 FS+5d, EN24312005 | 100% | KM Drwgs preparation by Cheljabinsk [53 t] | EN27312005 | EN27312005 | 87B | 31 | N02Z | 200 |  | E | N | EN27 | 3120 | de | LND | Chel |  |  |  | N02Z |  | 0,00 |
| EN643120 |  | CA31 Blower Sec SK3104 - Check Grating Cut-Out drwgs |  | 22d | 2010-06-01 A | 2010-06-30 A | EN673120 | 100% |  | EN643120 | EN643120 | 87B | 31 | N02Z | 200 | C | E | N | EN67 | 3120 | de | LND | LND |  |  | 200 | N02Z |  |  |
| EN27312015 |  | CA31 Blower Sec SK3104 - Auxiliary Structures/Platforms KM drwgs |  | 85d | 2010-08-30 A | 2010-12-28 A | P3N01D, EN27312005 FF | 100% |  | EN27312015 | EN27312015 | 87B | 31 | N02Z | 200 |  | E | N | EN27 | 3120 | de | LND | Chel |  |  |  | N02Z |  |  |
| EN27312010 |  | CA31 Blower Sec SK3104 - Check KM drwgs Roof Girders/Cladding |  | 10d | 2011-01-12 A | 2011-01-25 A | EN27312005 FS+10d | 100% |  | EN27312010 | EN27312010 | 87B | 31 | N02Z | 200 |  | E | N | EN27 | 3120 | de | LND | LND |  |  |  | N02Z |  |  |
| EN27312020 |  | CA31 Blower Sec SK3104 - Check KM drwgs Auxiliary Structures/Platforms |  | 10d | 2011-01-12 A | 2011-01-25 A | EN27312015 FS+10d | 100% |  | EN27312020 | EN27312020 | 87B | 31 | N02Z | 200 |  | E | N | EN27 | 3120 | de | LND | LND |  |  |  | N02Z |  |  |
| EN283120 |  | CA31 Blower Sec SK3104 - Shop dwgs(KMD) by Vendo |  | 30d | 2011-01-21 A | 2011-03-03 A | EN27312010 FF+27d, EN27312020 FF | 100% |  | EN283120 | EN283120 | 87B | 31 | N02Z | 200 |  | E | N | EN28 | 3120 | de | LND | Chel |  |  |  | N02Z |  |  |
| EN683120 |  | CA31 Blower Sec SK3104 - Grating Fabrication drwgs |  | 25d | 2011-01-28 A | 2011-03-03 A | EN283120 FF, EN673120 | 100% |  | EN683120 | EN683120 | 87B | 31 | N02Z | 200 | C | E | N | EN68 | 3120 | de | LND | Chel |  |  | 200 | N02Z |  |  |

Notes:
- EC423120: P3 Activity Log Info: fixed Layout
- EC443120: P3 Activity Log Info: incl. PMT approval
- EC221320: P3 Activity Log Info: TKB-B Keyplan to Subcontractor
- EC45312005: P3 Activity Log Info: incl. PMT approval
- EC45312015: P3 Activity Log Info: incl. PMT approval
- EC45312010: P3 Activity Log Info: incl. PMT approval

| ID | WBS | Activity | Type | Duration | Start | Finish | Predecessors | Complete | Resources | UDF_SAVE ACTID | UDF_SAVE ACT ID | Department | Constr. Area | Inquiry/Order No | PMT-Area | PMT-Schedule Org | PMT-Discipline | PMT-Phase | PMT-Respons. | WBS Phase | WBS Discipline | WBS Type of Work | WBS Objects | IMS | UPT | TB26 Ressource Budget | Pro Unit/DocCode |
| --- | --- | --- | --- | --- | --- | --- | --- | --- | --- | --- | --- | --- | --- | --- | --- | --- | --- | --- | --- | --- | --- | --- | --- | --- | --- | --- | --- |
|  | H | **H HVAC** |  |  | 2008-10-06 | 2010-12-30 |  |  |  |  |  |  |  |  |  |  |  |  |  |  |  |  |  |  |  |  |  |
| EH203120 |  | CA31 Blower Sec - HVAC&Plumbing / Feed/Basic |  | 175d | 2008-10-06 A | 2009-06-23 A | AD2230 FF+20d | 100% |  | EH203120 | EH203120 | 87C | 31 | 999 | 200 | 200 | 035 | E | LND | E | H | EH20 | 3120 | OTH | LND |  |  |
| EH30312005 |  | CA31 Blower Sec - HVAC Layouts Dwgs AFC |  | 276d | 2009-10-19 A | 2010-11-22 A | EH203120, EH30311005 SS+25d | 100% | TKB-H [360 h] | EH30312005 | EH30312005 | 87C | 31 |  | 200 | 200 | 035 | E | LNK | E | H | EH30 | 3120 | OTH | LND | 360,00 | 3104H23 |
| EH40312005 |  | CA31 Blower Sec - HVAC Calculations&Flow Diagrams |  | 276d | 2009-10-19 A | 2010-11-22 A | EH30312005 SS | 100% | TKB-H [240 h] | EH40312005 | EH40312005 | 87C | 31 |  | 200 | 200 | 035 | E | LNK | E | H | EH40 | 3120 | OTH | LND | 240,00 | 3104H22 |
| EH073120 |  | CA31 Blower Sec - Issue of Dwgs&Doc's by RDI | level of effort | 221d | 2010-01-11 A | 2010-11-22 A | EH40312010 FF, EH30312005 FF, EH30312005 SS+55d | 100% | TKB-H [4000 h] | EH073120 | EH073120 | 87C | 31 |  | 200 | 200 | 035 | E | LNK | E | H | EH30 | 3120 | OTH | LND | 4000,00 |  |
| EH30312010 |  | CA31 Blower Sec - HVAC Layouts Dwgs IFC | milestone | 0d | 2010-04-16 A | 2010-04-16 A | EH30312005 FF-25d | 100% |  | EH30312010 | EH30312010 | 87C | 31 |  | 200 | 200 | 035 | E | LNK | E | H | EH30 | 3120 | OTH | LND |  |  |
| EH40312010 |  | CA31 Blower Sec - HVAC Calc./Diagrams IFC | milestone | 0d | 2010-04-16 A | 2010-04-16 A | EH40312005 FF-15d | 100% |  | EH40312010 | EH40312010 | 87C | 31 |  | 200 | 200 | 035 | E | LNK | E | H | EH40 | 3120 | OTH | LND |  |  |
| EH30312015 |  | CA31 Blower Sec - Review HVAC Layout Dwgs |  | 181d | 2010-04-16 A | 2010-12-30 A | EH30312010 | 100% | TKB-H [360 h] | EH30312015 | EH30312015 | 87C | 31 |  | 200 | 200 | 035 | E | LND | E | H | EH30 | 3120 | OTH | LND | 360,00 |  |
| EH053120 |  | CA31 Blower Sec - Final Loads f.Civil/StrSteel | milestone | 0d | 2010-11-22 A | 2010-11-22 A | EH30312005 FF, E3H0150 SF | 100% |  | EH053120 | EH053120 | 87C | 31 | 999 | 200 |  |  |  | LNK | E | H | EH12 | 3120 | OTH | LND |  |  |
| EH243120 |  | CA31 Blower Sec - Wall & Floor open.details | milestone | 0d | 2010-11-22 A | 2010-11-22 A | EH053120 FF, HEH24 FF, E3H0150 SF | 100% |  | EH243120 | EH243120 | 87C | 31 | 999 | 200 | 200 | 035 | E | LNK | E | H | EH24 | 3120 | OTH | LND |  | 3104H21 |
|  | B | **B Mechanical - Stationary Equipment** |  |  | 2009-04-01 | 2009-04-01 |  |  |  |  |  |  |  |  |  |  |  |  |  |  |  |  |  |  |  |  |  |
| EB053120 |  | CA31 Blower Sec - Final Loads for Struc Steel | milestone | 0d | 2009-04-01 A | 2009-04-01 A | E3A1320 SF | 100% |  | EB053120 | EB053120 | 869 | 31 | 999 | 200 |  |  |  | LND | E | B | EB05 | 3120 | 3 | LND |  |  |
|  | M | **M Mechanical - Rotating Equipment** |  |  | 2009-04-01 | 2009-04-01 |  |  |  |  |  |  |  |  |  |  |  |  |  |  |  |  |  |  |  |  |  |
| EM053120 |  | CA31 Blower Sec - Final Loads for Struc Steel | milestone | 0d | 2009-04-01 A | 2009-04-01 A | E3U1050 FF | 100% |  | EM053120 | EM053120 | 867 | 31 | 999 | 200 |  |  |  | LND | E | M | EM05 | 3120 | I | LND |  |  |
|  | R | **R Piping** |  |  | 2008-04-01 | 2011-01-14 |  |  |  |  |  |  |  |  |  |  |  |  |  |  |  |  |  |  |  |  |  |
| ER153120 |  | CA31 Blower Sec - Conceptual Piping |  | 169d | 2008-04-01 A | 2008-11-28 A | F2760 | 100% |  | ER153120 | ER153120 | 876 | 31 | 999 | 200 |  |  |  | LNZ | E | R | ER15 | 3120 | PL | LND |  |  |
| ER303120 |  | CA31 Blower Sec - CAD Model Piping / Eqpt |  | 489d | 2008-07-01 A | 2010-06-15 A | ER393120 FF+15d, ER153120 SS | 100% |  | ER303120 | ER303120 | 876 | 31 | 999 | 200 |  |  |  | LND | E | R | ER30 | 3120 | PL | LND |  |  |
| ER163120 |  | CA31 Blower Sec - prel Loads for Civil |  | 14d | 2008-09-22 A | 2008-10-10 A | ER153120 FF | 100% |  | ER163120 | ER163120 | 876 | 31 | 999 | 200 |  |  |  | LNZ | E | R | ER16 | 3120 | PL | LND |  |  |
| ER363120 |  | CA31 Blower Sec - CAD Model Review 60% |  | 10d | 2009-10-14 A | 2009-10-27 A | F4035 FF | 100% |  | ER363120 | ER363120 | 876 | 31 | 999 | 200 |  |  |  | LND | E | R | ER36 | 3120 | 2 | LND |  |  |
| ER423120 |  | CA31 Blower Sec - Stress Calculation |  | 70d | 2009-11-16 A | 2010-02-26 A | ER363120 | 100% |  | ER423120 | ER423120 | 872 | 31 | 999 | 200 |  |  |  | LND | E | R | ER42 | 3120 | PL | LND |  |  |
| ER193120 |  | CA31 Blower Sec - Final Loads for Civil | milestone | 0d | 2009-11-17 A | 2009-11-17 A | ER193110 FF+5d, EC463120 SF-30d, ER163120 FF | 100% |  | ER193120 | ER193120 | 876 | 31 | 999 | 200 |  |  |  | LND | E | R | ER19 | 3120 | PL | LND |  |  |
| ER393120 |  | CA31 Blower Sec - CAD Model Review 90% |  | 10d | 2010-04-26 A | 2010-05-07 A | F9250 SS | 100% |  | ER393120 | ER393120 | 876 | 31 | 999 | 200 |  |  |  | LND | E | R | ER39 | 3120 | 3 | LND |  |  |
| ER453120 |  | CA31 Blower Sec - Piping Isometrics |  | 142d | 2010-06-02 A | 2010-12-17 A | ER423120, A1KL0025, ER393120 FS+10d, ER303120 FF+20d | 100% |  | ER453120 | ER453120 | 876 | 31 | 999 | 200 |  |  |  | LND | E | R | ER45 | 3120 | 5 | LND |  |  |
| ER45312005 |  | CA31 Blower Sec - Piping Isometrics (ZEP) |  | 141d | 2010-06-03 A | 2010-12-17 A | ER303120 FF+20d, ER393120 FS+10d, ER423120 | 100% |  | ER45312005 | ER45312005 | 876 | 31 | 999 | 200 |  |  |  | ZEP | E | R | ER45 | 3120 | 5 | LND |  |  |
| ER493120 |  | CA31 Blower Sec - Design Check/ Rel.Isos&BOM |  | 119d | 2010-07-29 A | 2011-01-14 A | ER453120 SS+40d, ER45312005 SS+40d | 100% |  | ER493120 | ER493120 | 876 | 31 | 999 | 200 |  |  |  | LND | E | R | ER49 | 3120 | 5 | LND |  |  |
| ER49312005 |  | CA31 Blower Sec - Design Check/Rel.Isos&BOM ZEP |  | 119d | 2010-07-29 A | 2011-01-14 A | ER45312005 SS+40d, ER453120 SS+40d | 100% |  | ER49312005 | ER49312005 | 876 | 31 | 999 | 200 |  |  |  | ZEP | E | R | ER49 | 3120 | 5 | LND |  |  |
| ER443120 |  | CA31 Blower Sec - Piping Isometrics (UG) |  | 31d | 2010-09-24 A | 2010-11-05 A | EC303120 SS+20d, ER440000 SS | 100% |  | ER443120 | ER443120 | 876 | 31 | 999 | 200 | 200 |  | E | LND | E | R | ER44 | 3120 | 4 | LND |  |  |

| ID | WBS | Activity | Type | Duration | Start | Finish | Predecessors | Complete | UDF_SAVE ACTID | UDF_SAVE ACT ID | Department | Constr. Area | Inquiry/Order No | PMT-Phase | PMT-Respons. | WBS Phase | WBS Discipline | WBS Type of Work | WBS Objects | IMS | UPT | Pro Unit/DocCode | PMT-Area | PMT-Schedule Org | Zeigen/n. Zeigen |
| --- | --- | --- | --- | --- | --- | --- | --- | --- | --- | --- | --- | --- | --- | --- | --- | --- | --- | --- | --- | --- | --- | --- | --- | --- | --- |
|  | E | **E Electrical** |  |  | 2008-10-06 | 2010-12-17 |  |  |  |  |  |  |  |  |  |  |  |  |  |  |  |  |  |  |  |
| EE46312005 |  | CA31 Blower Sec - prelimLoads f.Civil / StrSteel |  | 15d | 2008-10-06 A | 2008-10-24 A | F3060 FF | 100% | EE46312005 | EE46312005 | 874 | 31 | 999 | E | LND | E | E | EE11 | 3120 | E | LND |  |  |  |  |
| EE903120 |  | CA31 Blower Sec - Earthing Details |  | 30d | 2009-02-23 A | 2009-04-03 A | EE903110 SS | 100% | EE903120 | EE903120 | 874 | 31 | 999 | E | LND | E | E | EE90 | 3120 | E | LND |  |  |  |  |
| EE46312008 |  | CA31 Blower Sec - Final Loads f.Civil / StrSteel |  | 20d | 2009-10-23 A | 2009-11-20 A | EE46312005 | 100% | EE46312008 | EE46312008 | 874 | 31 | 999 | E | LND | E | E | EE12 | 3120 | E | LND |  |  |  |  |
| EE46312010 |  | CA31 Blower Sec - El. CableTray Layout Pl. / LOP's 1st Issue |  | 104d | 2009-12-07 A | 2010-05-07 A | EE460000, F4035 FS+80d | 100% | EE46312010 | EE46312010 | 874 | 31 | 999 | E | LND | E | E | EE46 | 3120 | E | LND |  |  |  |  |
| EE563120 |  | CA31 Blower Sec - Cable Pulling Details |  | 119d | 2009-12-10 A | 2010-06-04 A | EE46312010 FF, EE500130 | 100% | EE563120 | EE563120 | 874 | 31 | 999 | E | LND | E | E | EE56 | 3120 | E | LND |  |  |  |  |
| EE763120 |  | CA31 Blower Sec - Layout Plan Light.& Sockets 1st Issue |  | 229d | 2010-01-26 A | 2010-12-17 A | EE000180, EC503120 SF+10d | 100% | EE763120 | EE763120 | 874 | 31 | 999 | E | LNK | E | E | EE76 | 3120 | E | LND |  |  |  |  |
|  | J | **J Instrumentation** |  |  | 2008-10-06 | 2010-11-26 |  |  |  |  |  |  |  |  |  |  |  |  |  |  |  |  |  |  |  |
| EJ46312005 |  | CA31 Blower Sec - prelimLoads f.Civil / StrSteel |  | 15d | 2008-10-06 A | 2008-10-24 A | F3060 FF | 100% | EJ46312005 | EJ46312005 | 86E | 31 | 999 | E | LND | E | J | EJ11 | 3120 | I | LND | 999 |  |  |  |
| EJ46312008 |  | CA31 Blower Sec - Final Loads f.Civil / StrSteel |  | 10d | 2009-11-06 A | 2009-11-20 A | EJ46312005 | 100% | EJ46312008 | EJ46312008 | 86E | 31 | 999 | E | LND | E | J | EJ12 | 3120 | I | LND | 999 |  |  |  |
| EJ363120 |  | CA31 Blower Sec - Hook-Up drwgs 1st Issue |  | 100d | 2010-01-18 A | 2010-06-10 A | F4035 FS+50d, A1EJ0080 | 100% | EJ363120 | EJ363120 | 86E | 31 | 999 | C | LEI | E | J | EJ36 | 3120 | I | LND | 999 | 200 | 200 |  |
| EJ46312010 |  | CA31 Blower Sec - Instr Cable Tray Layout Plans 1st Issue |  | 48d | 2010-03-01 A | 2010-05-07 A | F9250 FS+10d, EE46312010 FF, F4035 FF+65d | 100% | EJ46312010 | EJ46312010 | 86E | 31 | 999 | E | LEI | E | J | EJ41 | 3120 | I | LND | 999 |  |  |  |
| EJ323120 |  | CA31 Blower Sec - JB Location drwgs |  | 53d | 2010-05-26 A | 2010-08-06 A | F4035, F9250 FF+35d | 100% | EJ323120 | EJ323120 | 86E | 31 | 999 | C | ZEP | E | J | EJ37 | 3120 | I | LND | 999 | 200 | 200 |  |
| EJ803120 |  | CA31 Blower Sec - Loop Diagrams |  | 70d | 2010-08-20 A | 2010-11-26 A | A1EJ0040 SF, EJ800010 | 100% | EJ803120 | EJ803120 | 86E | 31 | 999 | E | LEI | E | J | EJ80 | 3120 | I | LND | 999 |  |  |  |
|  | 3130 | **3130 Service Area - CA31** |  |  | 2008-03-03 | 2011-04-18 |  |  |  |  |  |  |  |  |  |  |  |  |  |  |  |  |  |  |  |
|  | 0B | **0B General Activities** |  |  | 2009-01-03 | 2009-01-03 |  |  |  |  |  |  |  |  |  |  |  |  |  |  |  |  |  |  |  |
| E0203130 |  | CA31 Service Area - freeze constr. concept | milestone | 0d | 2009-01-03 A | 2009-01-03 A | F3600 | 100% | E0203130 | E0203130 | 87A | 31 | 999 | E |  | E | 0B | E020 | 3130 | INS | LND |  | 200 |  |  |
|  | C | **C Civil** |  |  | 2008-03-03 | 2011-04-18 |  |  |  |  |  |  |  |  |  |  |  |  |  |  |  |  |  |  |  |
| EC423130 |  | CA31 Service Area - Building Concept |  | 171d | 2008-03-03 A | 2008-11-04 A | F2760 | 100% | EC423130 | EC423130 | 87A | 31 | 999 |  | LND | E | C | EC42 | 3130 | cq | LND |  | 200 |  |  |
| EC443130 |  | CA31 Service Area - Building Layout drwgs IFD |  | 43d | 2009-05-26 A | 2009-07-24 A | E0203130, EC423130, AD2230 FF+30d, EC443100 FF, EC221330 FF, EC60310002 FF, EC60310010 FF | 100% | EC443130 | EC443130 | 87A | 31 | 999 |  | LND | E | C | EC44 | 3130 | cq | LND | 3103C01 | 200 |  |  |
| EC221330 |  | CA31 Service Area - Civil Foundation Loads |  | 20d | 2009-06-10 A | 2009-07-07 A | EN253130, ER163130 | 100% | EC221330 | EC221330 | 87A | 31 | 999 |  | LND | E | C | EC22 | 3130 | de | LND |  | 200 |  |  |
| EC463130 |  | CA31 Service Area - Civil Static Calc Bldg |  | 199d | 2009-09-14 A | 2010-06-30 A | EC463120 SS, P3C00D FS+10d, EC133100 SS, EC443130 | 100% | EC463130 | EC463130 | 87A | 31 | 999 |  | LNK | E | C | EC46 | 3130 | de | LND | 3103C14 | 200 |  | C1 |
| EC45313005 |  | CA31 Service Area - Building Layout drwgs AFC |  | 251d | 2009-09-28 A | 2010-09-24 A | EC463130 SS+10d, P3C00D FS+10d, EC443130, EC48100, AD2230 | 100% | EC45313005 | EC45313005 | 87A | 31 | 999 | E | LNK | E | C | EC45 | 3130 | ar | LND | 3103C13 | 200 |  |  |
| EC153130 |  | CA31 Service Area - Piling drwgs AFC |  | 35d | 2009-10-02 A | 2009-11-20 A | EC15000010, EC463130 SS+14d | 100% | EC153130 | EC153130 | 87A | 31 | 999 |  | LNK | E | C | EC15 | 3130 | PI | LND | 3103C16 | 200 |  | C1 |
| EC48313003 |  | CA31 Service Area - Formw/Reinf drwgs Str Found. AFC |  | 111d | 2009-10-23 A | 2010-04-06 A | EC153130 SS+15d | 100% | EC48313003 | EC48313003 | 87A | 31 | 999 | E | LNK | E | C | EC48 | 3130 | ar | LND | 3103C21 | 200 | 200 |  |
| EC48313004 |  | CA31 Service Area - Precast Layout drwgs AFC |  | 187d | 2009-10-23 A | 2010-07-23 A | EC153130 SS+15d | 100% | EC48313004 | EC48313004 | 87A | 31 | 999 | E | LNK | E | C | EC48 | 3130 | PRE | LND | 3103C31 | 200 | 200 |  |
| EC48313005 |  | CA31 Service Area - Formw/Reinf drwgs Str GF +0,00 AFC |  | 105d | 2009-11-02 A | 2010-04-06 A | EC153130 FF+20d, EC48313003 SS+5d, EC463130 SS+35d | 100% | EC48313005 | EC48313005 | 87A | 31 | 999 | E | LNK | E | C | EC48 | 3130 | ar | LND | 3103C22 | 200 | 200 |  |
| EC48313010 |  | CA31 Service Area - Formw/Reinf drwgs Struc +6,90m AFC |  | 226d | 2009-11-16 A | 2010-10-08 A | EC48313005 SS+10d | 100% | EC48313010 | EC48313010 | 87A | 31 | 999 | E | LNK | E | C | EC48 | 3130 | ar | LND | 3103C23 | 200 | 200 |  |
| EC48313006 |  | CA31 Service Area - Precast Formw/Reinf. drwgs AFC <6,90m |  | 178d | 2009-12-29 A | 2010-09-10 A | E3E0250 SF, EC48313004 SS+10d | 100% | EC48313006 | EC48313006 | 87A | 31 | 999 | E | LNK | E | C | EC48 | 3130 | ar | LND | 3103C53 | 200 | 200 |  |
| EC48313008 |  | CA31 Service Area - Precast Formw/Reinf. drwgs AFC <13,50m |  | 168d | 2010-01-14 A | 2010-09-10 A | EC48313006 FF | 100% | EC48313008 | EC48313008 | 87A | 31 | 999 | E | LNK | E | C | EC48 | 3130 | ar | LND | 3103C54 | 200 | 200 |  |
| EC45313015 |  | CA31 Service Area - Review Building Layout drwgs |  | 10d | 2010-01-25 A | 2010-02-05 A | EC45313010 | 100% | EC45313015 | EC45313015 | 87A | 31 |  | E | LND | E | C | EC45 | 3130 | ar | LND |  | 200 |  |  |
| EC503130 |  | CA31 Service Area - Architec Det.drwgs Bldg AFC |  | 274d | 2010-03-15 A | 2011-04-11 A | EC45313005 FF+20d | 100% | EC503130 | EC503130 | 87A | 31 | 999 | E | LNK | E | C | EC50 | 3130 | ar | LND | 3103C41 | 200 | 200 |  |
| EC523130 |  | CA31 Service Area - False Floor drwgs AFC |  | 279d | 2010-03-15 A | 2011-04-18 A | EC603130 FF | 100% | EC523130 | EC523130 | 87A | 31 | 999 | E | LNK | E | C | EC52 | 3130 | ar | LND | 3103C42 | 200 | 200 |  |
| EC603130 |  | CA31 Service Area - Paving drwgs AFC |  | 154d | 2010-03-15 A | 2010-10-20 A | EC503130 SS+10d, EC303130 SS | 100% | EC603130 | EC603130 | 87A | 31 | 999 | E | LNK | E | C | EC60 | 3130 | de | LND | 3103C96 | 200 | 200 |  |
| EC45313010 |  | CA31 Service Area - Building Layout drwgs IFC | milestone | 0d | 2010-06-28 A | 2010-06-28 A | EC45313005 FF-30d | 100% | EC45313010 | EC45313010 | 87A | 31 | 999 | E | LNK | E | C | EC45 | 3130 | ar | LND |  | 200 |  |  |

Notes:
- EC423130: P3 Activity Log Info: fixed Layout
- EC443130: P3 Activity Log Info: incl. PMT approval
- EC221330: P3 Activity Log Info: TKB-B Keyplan to Subcontractor
- EC45313005: P3 Activity Log Info: incl. PMT approval
- EC45313015: P3 Activity Log Info: incl. PMT approval
- EC45313010: P3 Activity Log Info: incl. PMT approval

| ID | WBS | Activity | Type | Duration | Start | Finish | Predecessors | Complete | Constraint | Resources | UDF_SAVE ACTID | UDF_SAVE ACT ID | Department | Type of Work | Constr. Area | Inquiry/Order No | PMT-Area | PMT-Schedule Org | PMT-Discipline | PMT-Phase | PMT-Respons. | Zeigen/n. Zeigen | WBS Phase | WBS Discipline | WBS Type of Work | WBS Objects | IMS | UPT | TB26 Ressource Budget | Pro Unit/DocCode |
| --- | --- | --- | --- | --- | --- | --- | --- | --- | --- | --- | --- | --- | --- | --- | --- | --- | --- | --- | --- | --- | --- | --- | --- | --- | --- | --- | --- | --- | --- | --- |
|  | N | **N Structural Steel** |  |  | 2008-03-03 | 2011-03-11 |  |  |  |  |  |  |  |  |  |  |  |  |  |  |  |  |  |  |  |  |  |  |  |  |
| EN153130 |  | CA31 Service Area - CAD Model/Concepts StrSteel |  | 126d | 2008-03-03 A | 2008-08-29 A | AD2230 FF | 100% |  |  | EN153130 | EN153130 | 87B | N02Д | 31 | N02Д | 200 | 200 | 055 | E | LND | 0 | E | N | EN15 | 3130 | de | LND |  |  |
| EN21313005 |  | CA31 Service Area SK3103 - GA-Drwgs + Fdtn Loads |  | 77d | 2009-01-26 A | 2009-05-15 A | EJ46313005, EN153130 FF, EE46313005, AD2230 FS+35d | 100% |  |  | EN21313005 | EN21313005 | 87B | N02Д | 31 | N02Д | 200 |  |  |  | LND |  | E | N | EN21 | 3130 | de | LND |  |  |
| EN24313005 |  | CA31 Service Area SK3103 - StaticCalc f.Fdtn Loads |  | 15d | 2009-05-18 A | 2009-06-09 A | EN21313005 | 100% |  |  | EN24313005 | EN24313005 | 87B | N02Д | 31 | N02Д | 200 |  |  |  | LND |  | E | N | EN24 | 3130 | de | LND |  |  |
| EN253130 |  | CA31 Service Area SK3103 - Loads for Civil | milestone | 0d | 2009-06-09 A | 2009-06-09 A | EN24313005 FF | 100% |  |  | EN253130 | EN253130 | 87B | N02Д | 31 | N02Д | 200 | 200 | 055 | E | LND | 0 | E | N | EN25 | 3130 | de | LND |  |  |
| EN21313010 |  | CA31 Service Area SK3103 - GA-Drwgs + Final Loads |  | 16d | 2009-11-16 A | 2009-12-08 A | EE46313008, EJ46313008, EN21313005 | 100% |  | TKB-S [192 h] | EN21313010 | EN21313010 | 87B | N02Д | 31 | N02Д | 200 |  |  |  | LND |  | E | N | EN21 | 3130 | de | LND | 192,00 |  |
| EN24313010 |  | CA31 Service Area SK3103 - Final Static Calc |  | 82d | 2009-12-09 A | 2010-04-09 A | EN21313010 | 100% |  |  | EN24313010 | EN24313010 | 87B | N02Д | 31 | N02Д | 200 |  |  |  | LNK |  | E | N | EN24 | 3130 | de | LND |  |  |
| EN263130 |  | CA31 Service Area SK3103 - Layout dwgs input for KM dwgs |  | 58d | 2010-01-25 A | 2010-04-16 A | EN24313010 FF+5d, F4035 FF+20d | 100% |  | TKB-S [240 h] | EN263130 | EN263130 | 87B | N02Д | 31 | N02Д | 200 |  |  |  | LND |  | E | N | EN26 | 3130 | st | LND | 240,00 |  |
| EN803130 |  | CA31 Service Area - KM drwgs Cladding |  | 204d | 2010-03-10 A | 2010-12-28 A | EN27313005 FF, ER393130 FF+19d | 100% |  |  | EN803130 | EN803130 | 87B | N02Д | 31 | N02Д | 200 | 200 |  | E | Chel |  | E | N | EN80 | 3130 | de | LND |  | 3103C61 |
| EN27313005 |  | CA31 Service Area SK3103 - Roof Girders KM drwgs |  | 190d | 2010-03-30 A | 2010-12-28 A | EN263130 FS+10d, EN24313005 | 100% |  | KM Drwgs preparation by Cheljabinsk [76 t] | EN27313005 | EN27313005 | 87B | N02Д | 31 | N02Д | 200 |  |  |  | Chel |  | E | N | EN27 | 3130 | de | LND | 0,00 |  |
| EN673130 |  | CA31 Service Area SK3103 - Grating Cut-Out drwgs |  | 8d | 2010-05-10 A | 2010-05-20 A | ER423130 FF, F9250 FF+10d | 100% |  | TKB-S [80 h] | EN673130 | EN673130 | 87B | N02Д | 31 | N02Д | 200 | 200 |  | C | LND |  | E | N | EN67 | 3130 | de | LND | 80,00 |  |
| EN643130 |  | CA31 Service Area SK3103 - Check Grating Cut-Out drwgs |  | 22d | 2010-06-01 A | 2010-06-30 A | EN673130 | 100% |  |  | EN643130 | EN643130 | 87B | N02Д | 31 | N02Д | 200 | 200 |  | C | LND |  | E | N | EN67 | 3130 | de | LND |  |  |
| EN27313010 |  | CA31 Service Area SK3103 - Check KM drwgs Roof Girders/Cladding |  | 15d | 2011-01-10 A | 2011-01-28 A | EN27313005 | 100% | start on 2011-01-10 |  | EN27313010 | EN27313010 | 87B | N02Д | 31 | N02Д | 200 |  |  |  | LND |  | E | N | EN27 | 3130 | de | LND |  |  |
| EN283130 |  | CA31 Service Area SK3103 - Shop dwgs(KMD) by Vendo |  | 25d | 2011-01-31 A | 2011-03-04 A | EN27313010 | 100% |  |  | EN283130 | EN283130 | 87B | N02Д | 31 | N02Д | 200 |  |  |  | Chel |  | E | N | EN28 | 3130 | de | LND |  |  |
| EN683130 |  | CA31 Service Area SK3103 - Grating Fabrication drwgs |  | 30d | 2011-01-31 A | 2011-03-11 A | EN283130 SS, EN673130 | 100% |  |  | EN683130 | EN683130 | 87B | N02Д | 31 | N02Д | 200 | 200 |  | C | Chel |  | E | N | EN68 | 3130 | de | LND |  |  |
|  | H | **H HVAC** |  |  | 2008-10-06 | 2010-12-30 |  |  |  |  |  |  |  |  |  |  |  |  |  |  |  |  |  |  |  |  |  |  |  |  |
| EH203130 |  | CA31 Service Area - HVAC&Plumbing / Feed/Basic |  | 175d | 2008-10-06 A | 2009-06-23 A | AD2230 FF+20d | 100% |  |  | EH203130 | EH203130 | 87C |  | 31 | 999 | 200 | 200 | 035 | E | LND |  | E | H | EH20 | 3130 | OTH | LND |  |  |
| EH30313005 |  | CA31 Service Area - HVAC Layouts Dwgs AFC |  | 271d | 2009-10-26 A | 2010-11-22 A | EH203130, HEH30 FF, EH30312005 SS+5d | 100% |  | TKB-H [800 h] | EH30313005 | EH30313005 | 87C |  | 31 |  | 200 | 200 | 035 | E | LNK |  | E | H | EH30 | 3130 | OTH | LND | 800,00 | 3103H23 |
| EH40313005 |  | CA31 Service Area - HVAC Calculations&Flow Diagrams |  | 271d | 2009-10-26 A | 2010-11-22 A | EH30313005 SS | 100% |  | TKB-H [640 h] | EH40313005 | EH40313005 | 87C |  | 31 |  | 200 | 200 | 035 | E | LNK |  | E | H | EH40 | 3130 | OTH | LND | 640,00 | 3103H22 |
| EH073130 |  | CA31 Service Area - Issue of Dwgs&Doc's by RDI | level of effort | 216d | 2010-01-18 A | 2010-11-22 A | EH40313010 FF, EH30313005 SS+55d, EH30313005 FF | 100% |  | TKB-H [8888 h] | EH073130 | EH073130 | 87C |  | 31 |  | 200 | 200 | 035 | E | LNK |  | E | H | EH30 | 3130 | OTH | LND | 8888,00 |  |
| EH30313010 |  | CA31 Service Area - HVAC Layouts Dwgs IFC | milestone | 0d | 2010-04-16 A | 2010-04-16 A | EH30313005 FF-20d | 100% |  |  | EH30313010 | EH30313010 | 87C |  | 31 |  | 200 | 200 | 035 | E | LNK |  | E | H | EH30 | 3130 | OTH | LND |  |  |
| EH40313010 |  | CA31 Service Area - HVAC Calc./Diagrams IFC | milestone | 0d | 2010-04-16 A | 2010-04-16 A | EH40313005 FF-15d | 100% |  |  | EH40313010 | EH40313010 | 87C |  | 31 |  | 200 | 200 | 035 | E | LNK |  | E | H | EH40 | 3130 | OTH | LND |  |  |
| EH30313015 |  | CA31 Service Area - Review HVAC Layout Dwgs |  | 180d | 2010-04-19 A | 2010-12-30 A | EH30313010 | 100% |  | TKB-H [800 h] | EH30313015 | EH30313015 | 87C |  | 31 |  | 200 | 200 | 035 | E | LND |  | E | H | EH30 | 3130 | OTH | LND | 800,00 |  |
| EH053130 |  | CA31 Service Area - Final Loads f.Civil/StrSteel | milestone | 0d | 2010-11-22 A | 2010-11-22 A | EH30313005 FF, HEH12 FF, E3H0150 SF | 100% |  |  | EH053130 | EH053130 | 87C |  | 31 | 999 | 200 |  |  |  | LNK |  | E | H | EH12 | 3130 | OTH | LND |  |  |
| EH243130 |  | CA31 Service Area - Wall & Floor open.details | milestone | 0d | 2010-11-22 A | 2010-11-22 A | E3H0150 SF, HEH24 FF, EH053130 FF | 100% |  |  | EH243130 | EH243130 | 87C |  | 31 | 999 | 200 | 200 | 035 | E | LNK |  | E | H | EH24 | 3130 | OTH | LND |  | 3103H21 |

| ID | WBS | Activity | Type | Duration | Start | Finish | Predecessors | Complete | Resources | UDF_SAVE ACTID | UDF_SAVE ACT ID | Department | Constr. Area | Inquiry/Order No | PMT-Area | PMT-Respons. | WBS Phase | WBS Discipline | WBS Type of Work | WBS Objects | IMS | UPT | PMT-Schedule Org | PMT-Phase | TB26 Ressource Budget | Pro Unit/DocCode |
| --- | --- | --- | --- | --- | --- | --- | --- | --- | --- | --- | --- | --- | --- | --- | --- | --- | --- | --- | --- | --- | --- | --- | --- | --- | --- | --- |
|  | R | **R Piping** |  |  | 2008-04-01 | 2011-01-14 |  |  |  |  |  |  |  |  |  |  |  |  |  |  |  |  |  |  |  |  |
| ER153130 |  | CA31 Service Area - Conceptual Piping |  | 169d | 2008-04-01 A | 2008-11-28 A | F2760 | 100% |  | ER153130 | ER153130 | 876 | 31 | 999 | 200 | LNZ | E | R | ER15 | 3130 | PL | LND |  |  |  |  |
| ER303130 |  | CA31 Service Area - CAD Model Piping / Eqpt |  | 489d | 2008-07-01 A | 2010-06-15 A | ER153130 SS, ER393130 FF+15d | 100% |  | ER303130 | ER303130 | 876 | 31 | 999 | 200 | LND | E | R | ER30 | 3130 | PL | LND |  |  |  |  |
| ER163130 |  | CA31 Service Area - prel Loads for Civil |  | 14d | 2008-09-22 A | 2008-10-10 A | ER153130 FF | 100% |  | ER163130 | ER163130 | 876 | 31 | 999 | 200 | LNZ | E | R | ER16 | 3130 | PL | LND |  |  |  |  |
| ER363130 |  | CA31 Service Area - CAD Model Review 60% |  | 10d | 2009-10-14 A | 2009-10-27 A | F4035 FF | 100% |  | ER363130 | ER363130 | 876 | 31 | 999 | 200 | LND | E | R | ER36 | 3130 | 2 | LND |  |  |  |  |
| ER423130 |  | CA31 Service Area - Stress Calculation |  | 70d | 2009-11-16 A | 2010-02-26 A | ER363130 | 100% |  | ER423130 | ER423130 | 872 | 31 | 999 | 200 | LND | E | R | ER42 | 3130 | PL | LND |  |  |  |  |
| ER193130 |  | CA31 Service Area - Final Loads for Civil | milestone | 0d | 2009-11-17 A | 2009-11-17 A | ER193110 FF+5d, EC463130 SF-30d, ER163130 FF | 100% |  | ER193130 | ER193130 | 876 | 31 | 999 | 200 | LND | E | R | ER19 | 3130 | PL | LND |  |  |  |  |
| ER393130 |  | CA31 Service Area - CAD Model Review 90% |  | 10d | 2010-04-26 A | 2010-05-07 A | F9250 SS | 100% |  | ER393130 | ER393130 | 876 | 31 | 999 | 200 | LND | E | R | ER39 | 3130 | 3 | LND |  |  |  |  |
| ER453130 |  | CA31 Service Area - Piping Isometrics |  | 141d | 2010-06-03 A | 2010-12-17 A | ER393130 FS+10d, ER303130 FF+20d, ER453110 SS, ER423130, A1KL0025 | 100% |  | ER453130 | ER453130 | 876 | 31 | 999 | 200 | LND | E | R | ER45 | 3130 | 5 | LND |  |  |  |  |
| ER45313005 |  | CA31 Service Area - Piping Isometrics (ZEP) |  | 141d | 2010-06-03 A | 2010-12-17 A | ER45311005 SS, ER393130 FS+10d, ER303130 FF+20d, ER423130 | 100% |  | ER45313005 | ER45313005 | 876 | 31 | 999 | 200 | ZEP | E | R | ER45 | 3130 | 5 | LND |  |  |  |  |
| ER493130 |  | CA31 Service Area - Design Check/ Rel.Isos&BOM |  | 119d | 2010-07-29 A | 2011-01-14 A | ER45313005 SS+40d, ER453130 SS+40d | 100% |  | ER493130 | ER493130 | 876 | 31 | 999 | 200 | LND | E | R | ER49 | 3130 | 5 | LND |  |  |  |  |
| ER49313005 |  | CA31 Service Area - Design Check/Rel.Isos&BOM ZEP |  | 119d | 2010-07-29 A | 2011-01-14 A | ER45313005 SS+40d, ER453130 SS+40d | 100% |  | ER49313005 | ER49313005 | 876 | 31 | 999 | 200 | ZEP | E | R | ER49 | 3130 | 5 | LND |  |  |  |  |
| ER443130 |  | CA31 Service Area - Piping Isometrics (UG) |  | 31d | 2010-09-24 A | 2010-11-05 A | EC303130 SS+20d, ER440000 SS | 100% |  | ER443130 | ER443130 | 876 | 31 | 999 | 200 | LND | E | R | ER44 | 3130 | 4 | LND | 200 | E |  |  |
|  | E | **E Electrical** |  |  | 2008-10-06 | 2010-12-17 |  |  |  |  |  |  |  |  |  |  |  |  |  |  |  |  |  |  |  |  |
| EE46313005 |  | CA31 Service Area - prelimLoads f.Civil / StrSteel |  | 15d | 2008-10-06 A | 2008-10-24 A | F3060 FF | 100% |  | EE46313005 | EE46313005 | 874 | 31 | 999 |  | LND | E | E | EE11 | 3130 | E | LND |  | E |  |  |
| EE903130 |  | CA31 Service Area - Earthing Details |  | 30d | 2009-02-23 A | 2009-04-03 A | EE903110 SS | 100% |  | EE903130 | EE903130 | 874 | 31 | 999 |  | LND | E | E | EE90 | 3130 | E | LND |  | E |  |  |
| EE46313008 |  | CA31 Service Area - Final Loads f.Civil / StrSteel |  | 20d | 2009-10-19 A | 2009-11-13 A | EE46313005 | 100% |  | EE46313008 | EE46313008 | 874 | 31 | 999 |  | LND | E | E | EE12 | 3130 | E | LND |  | E |  |  |
| EE46313010 |  | CA31 Service Area - El. CableTray Layout Pl. 1st Issue |  | 104d | 2009-12-07 A | 2010-05-07 A | F4035 FS+80d, EE460000 | 100% |  | EE46313010 | EE46313010 | 874 | 31 | 999 |  | LND | E | E | EE46 | 3130 | E | LND |  | E |  |  |
| EE563130 |  | CA31 Service Area - Cable Pulling Details |  | 119d | 2009-12-10 A | 2010-06-04 A | EE500130, EE46313010 FF | 100% |  | EE563130 | EE563130 | 874 | 31 | 999 |  | LND | E | E | EE56 | 3130 | E | LND |  | E |  |  |
| EE763130 |  | CA31 Service Area - Layout Plan Light.& Sockets 1st Issue |  | 229d | 2010-01-26 A | 2010-12-17 A | EE000180, EC503130 SF+10d | 100% |  | EE763130 | EE763130 | 874 | 31 | 999 |  | LNK | E | E | EE76 | 3130 | E | LND |  | E |  |  |
| EE203130 |  | CA31 Subst - Layout Plan ElectrSubstation |  | 78d | 2010-02-22 A | 2010-06-15 A | E3E01A50 FF, E3E0220 FF+15d, E3E01B50 SF | 100% | TAE [320 h] | EE203130 | EE203130 | 874 | 31 |  | 200 | LND | E | E | EE19 | 3130 | E | LND |  |  | 320,00 |  |
|  | J | **J Instrumentation** |  |  | 2008-10-06 | 2009-11-13 |  |  |  |  |  |  |  |  |  |  |  |  |  |  |  |  |  |  |  |  |
| EJ46313005 |  | CA31 Service Area - prelimLoads f.Civil / StrSteel |  | 15d | 2008-10-06 A | 2008-10-24 A | F3060 FF | 100% |  | EJ46313005 | EJ46313005 | 86E | 31 | 999 |  | LND | E | J | EJ11 | 3130 | I | LND |  | E |  | 999 |
| EJ46313008 |  | CA31 Service Area - Final Loads f.Civil / StrSteel |  | 10d | 2009-11-02 A | 2009-11-13 A | EJ46313005 | 100% |  | EJ46313008 | EJ46313008 | 86E | 31 | 999 |  | LND | E | J | EJ12 | 3130 | I | LND |  | E |  | 999 |

| ID | WBS | Activity | Type | Duration | Start | Finish | Predecessors | Complete | Constraint | Resources | UDF_SAVE ACTID | UDF_SAVE ACT ID | Department | Constr. Area | Inquiry/Order No | PMT-Area | PMT-Phase | WBS Phase | WBS Discipline | WBS Type of Work | WBS Objects | IMS | UPT | PMT-Respons. | Pro Unit/DocCode | Zeigen/n. Zeigen | PMT-Schedule Org | Type of Work | PMT-Discipline | TB26 Ressource Budget |
| --- | --- | --- | --- | --- | --- | --- | --- | --- | --- | --- | --- | --- | --- | --- | --- | --- | --- | --- | --- | --- | --- | --- | --- | --- | --- | --- | --- | --- | --- | --- |
|  | 3140 | **3140 Warehouse - CA31** |  |  | 2008-03-03 | 2011-04-25 |  |  |  |  |  |  |  |  |  |  |  |  |  |  |  |  |  |  |  |  |  |  |  |  |
|  | 0B | **0B General Activities** |  |  | 2009-01-03 | 2009-01-03 |  |  |  |  |  |  |  |  |  |  |  |  |  |  |  |  |  |  |  |  |  |  |  |  |
| E0203140 |  | CA31 Warehouse - freeze constr. concept | milestone | 0d | 2009-01-03 A | 2009-01-03 A | F3600 | 100% |  |  | E0203140 | E0203140 | 87A | 31 | 999 | 200 | E | E | 0B | E020 | 3140 | INS | LND |  |  |  |  |  |  |  |
|  | C | **C Civil** |  |  | 2008-03-03 | 2011-04-25 |  |  |  |  |  |  |  |  |  |  |  |  |  |  |  |  |  |  |  |  |  |  |  |  |
| EC423140 |  | CA31 Warehouse - Building Concept |  | 171d | 2008-03-03 A | 2008-11-04 A | F2760 | 100% |  |  | EC423140 | EC423140 | 87A | 31 | 999 | 200 |  | E | C | EC42 | 3140 | cq | LND | LND |  |  |  |  |  |  |
| EC443140 |  | CA31 Warehouse - Building Layout drwgs IFD |  | 39d | 2009-05-27 A | 2009-07-21 A | EC60310002 FF, EC443100 FF, EC423140, E0203140, EC221340 FF, AD2230 FF+30d, EC60310010 FF | 100% |  |  | EC443140 | EC443140 | 87A | 31 | 999 | 200 |  | E | C | EC44 | 3140 | cq | LND | LND | 3102C01 |  |  |  |  |  |
| EC221340 |  | CA31 Warehouse - Civil Foundation Loads |  | 20d | 2009-06-11 A | 2009-07-08 A | E3U0720 SF, EN253140, ER163140 | 100% |  |  | EC221340 | EC221340 | 87A | 31 | 999 | 200 |  | E | C | EC22 | 3140 | de | LND | LND |  |  |  |  |  |  |
| EC153140 |  | CA31 Warehouse - Piling drwgs AFC |  | 30d | 2009-09-07 A | 2009-10-16 A | EC463140 SS, EC15000010 | 100% |  |  | EC153140 | EC153140 | 87A | 31 | 999 | 200 |  | E | C | EC15 | 3140 | PI | LND | LNK | 3102C16 | C1 |  |  |  |  |
| EC463140 |  | CA31 Warehouse - Civil Static Calc Bldg Found. |  | 95d | 2009-09-07 A | 2010-01-22 A | EC443140, P3C00E FS+15d, P3C00D | 100% |  |  | EC463140 | EC463140 | 87A | 31 | 999 | 200 |  | E | C | EC46 | 3140 | de | LND | LNK | 3102C14 | C1 |  |  |  |  |
| EC45314005 |  | CA31 Warehouse - Building Layout drwgs AFC |  | 251d | 2009-09-28 A | 2010-09-24 A | EC48100, EC463140 SS+15d, P3C00D FS+5d, EC443140, P3C00E, AD2230 | 100% |  |  | EC45314005 | EC45314005 | 87A | 31 | 999 | 200 | E | E | C | EC45 | 3140 | ar | LND | LNK | 3102C13 |  |  |  |  |  |
| EC48314003 |  | CA31 Warehouse - Formw/Reinforce drwgs Found. AFC |  | 120d | 2009-10-12 A | 2010-04-06 A | EC153140 SS+20d, EC45314005 SS+10d | 100% |  |  | EC48314003 | EC48314003 | 87A | 31 | 999 | 200 | E | E | C | EC48 | 3140 | ar | LND | LNK | 3102C21 |  | 200 |  |  |  |
| EC48314004 |  | CA31 Warehouse - Precast Layout drwgs AFC |  | 161d | 2009-10-19 A | 2010-06-11 A | EC48314003 FF+10d, EC153140 SS+30d | 100% |  |  | EC48314004 | EC48314004 | 87A | 31 | 999 | 200 | E | E | C | EC48 | 3140 | PRE | LND | LNK | 3102C31 |  | 200 |  |  |  |
| EC48314006 |  | CA31 Warehouse - Precast Formw/Reinf. drwgs AFC |  | 161d | 2009-10-19 A | 2010-06-11 A | EC48314004 SS | 100% |  |  | EC48314006 | EC48314006 | 87A | 31 | 999 | 200 | E | E | C | EC48 | 3140 | ar | LND | LNK | 3102C53 |  | 200 |  |  |  |
| EC48314005 |  | CA31 Warehouse - Formw/Reinforce drwgs GF +1,20m AFC |  | 147d | 2009-10-26 A | 2010-05-31 A | EC463140 SS+35d, EC48314003 FF+10d | 100% |  |  | EC48314005 | EC48314005 | 87A | 31 | 999 | 200 | E | E | C | EC48 | 3140 | ar | LND | LNK | 3102C22 |  | 200 |  |  |  |
| EC503140 |  | CA31 Warehouse - Architec Det.drwgs Bldg AFC |  | 364d | 2009-11-16 A | 2011-04-25 A | EC45314005 SS | 100% |  |  | EC503140 | EC503140 | 87A | 31 | 999 | 200 | E | E | C | EC50 | 3140 | ar | LND | LNK | 3102C41 |  | 200 |  |  |  |
| EC45314010 |  | CA31 Warehouse - Building Layout drwgs IFC | milestone | 0d | 2009-12-15 A | 2009-12-15 A | EC45314005 FF-25d | 100% |  |  | EC45314010 | EC45314010 | 87A | 31 | 999 | 200 | E | E | C | EC45 | 3140 | ar | LND | LNK |  |  |  |  |  |  |
| EC45314015 |  | CA31 Warehouse - Review Building Layout drwgs |  | 10d | 2009-12-15 A | 2009-12-30 A | EC45314010 | 100% |  |  | EC45314015 | EC45314015 | 87A | 31 |  | 200 | E | E | C | EC45 | 3140 | ar | LND | LND |  |  |  |  |  |  |
| EC603140 |  | CA31 Warehouse - Paving drwgs AFC |  | 209d | 2009-12-22 A | 2010-10-20 A | EC503140 SS, EC303140 SS+20d | 100% |  |  | EC603140 | EC603140 | 87A | 31 | 999 | 200 | E | E | C | EC60 | 3140 | de | LND | LNK | 3102C96 |  | 200 |  |  |  |
|  | N | **N Structural Steel** |  |  | 2008-03-03 | 2011-04-01 |  |  |  |  |  |  |  |  |  |  |  |  |  |  |  |  |  |  |  |  |  |  |  |  |
| EN153140 |  | CA31 Warehouse - CAD Model/Concepts StrSteel |  | 126d | 2008-03-03 A | 2008-08-29 A | AD2230 FF | 100% |  |  | EN153140 | EN153140 | 87B | 31 | N02Ц | 200 | E | E | N | EN15 | 3140 | de | LND | LND |  | 0 | 200 | N02Ц | 055 |  |
| EN21314005 |  | CA31 Warehouse SK3102 - GA-Drwgs + Fdtn Loads |  | 78d | 2009-01-26 A | 2009-05-18 A | EE46314005, EJ46314005, AD2230 FS+35d, EN153140 FF, ER163140 | 100% |  |  | EN21314005 | EN21314005 | 87B | 31 | N02Ц | 200 |  | E | N | EN21 | 3140 | de | LND | LND |  |  |  | N02Ц |  |  |
| EN24314005 |  | CA31 Warehouse SK3102 - Static Calc f.Fdtn Loads |  | 15d | 2009-05-19 A | 2009-06-10 A | EN21314005 | 100% |  |  | EN24314005 | EN24314005 | 87B | 31 | N02Ц | 200 |  | E | N | EN24 | 3140 | de | LND | LND |  |  |  | N02Ц |  |  |
| EN253140 |  | CA31 Warehouse SK3102 - Loads for Civil | milestone | 0d | 2009-06-10 A | 2009-06-10 A | EN24314005 FF | 100% |  |  | EN253140 | EN253140 | 87B | 31 | N02Ц | 200 | E | E | N | EN25 | 3140 | de | LND | LND |  | 0 | 200 | N02Ц | 055 |  |
| EN21314010 |  | CA31 Warehouse SK3102 - GA-Drwgs + Final Loads |  | 15d | 2009-11-16 A | 2009-12-07 A | EN21314005, EE46314008, EJ46314008, EB053140, EM053140 | 100% |  | TKB-S [640 h] | EN21314010 | EN21314010 | 87B | 31 | N02Ц | 200 |  | E | N | EN21 | 3140 | de | LND | LND |  |  |  | N02Ц |  | 640,00 |
| EN24314010 |  | CA31 Warehouse SK3102 - Final Static Calc |  | 83d | 2009-12-08 A | 2010-04-09 A | EN21314010 | 100% |  |  | EN24314010 | EN24314010 | 87B | 31 | N02Ц | 200 |  | E | N | EN24 | 3140 | de | LND | LNK |  |  |  | N02Ц |  |  |
| EN263140 |  | CA31 Warehouse SK3102 - Layout dwgs input for KM dwgs |  | 68d | 2010-01-25 A | 2010-04-30 A | EN24314010 FF+15d, F4035 FF+20d | 100% |  | TKB-S [960 h] | EN263140 | EN263140 | 87B | 31 | N02Ц | 200 |  | E | N | EN26 | 3140 | st | LND | LND |  |  |  | N02Ц |  | 960,00 |
| EN27314005 |  | CA31 Warehouse SK3102 - Roof Girders KM drwgs |  | 154d | 2010-03-17 A | 2010-10-22 A | EN24314010 FF+5d, EN263140 FS+5d, EN24314005 | 100% |  | KM Drwgs preparation by Cheljabinsk [242 t] | EN27314005 | EN27314005 | 87B | 31 | N02Ц | 200 |  | E | N | EN27 | 3140 | de | LND | Chel |  |  |  | N02Ц |  | 0,00 |
| EN673140 |  | CA31 Warehouse SK3102 - Grating Cut-Out drwgs |  | 37d | 2010-05-25 A | 2010-07-14 A | ER423140 FF, F9250 FF+10d | 100% |  | TKB-S [320 h] | EN673140 | EN673140 | 87B | 31 | N02Ц | 200 | C | E | N | EN67 | 3140 | de | LND | LND |  |  | 200 | N02Ц |  | 320,00 |
| EN643140 |  | A31 Warehouse SK3102 - Check Grating Cut-Out drwgs |  | 4d | 2010-07-15 A | 2010-07-20 A | EN673140 | 100% |  |  | EN643140 | EN643140 | 87B | 31 | N02Ц | 200 | C | E | N | EN67 | 3140 | de | LND | LND |  |  | 200 | N02Ц |  |  |
| EN27314015 |  | CA31 Warehouse SK3102 - Auxiliary Structures KM drwgs |  | 35d | 2010-08-23 A | 2010-10-08 A | P3N01D FS+20d, EN27314005 FF | 100% |  |  | EN27314015 | EN27314015 | 87B | 31 | N02Ц | 200 |  | E | N | EN27 | 3140 | de | LND | Chel |  |  |  | N02Ц |  |  |
| EN27314025 |  | CA31 Warehouse SK3102 - Cladding KM drwgs |  | 77d | 2010-10-11 A | 2011-01-28 A | EN27314005 FF+25d, EN263140 | 100% |  |  | EN27314025 | EN27314025 | 87B | 31 | N02Ц | 200 |  | E | N | EN27 | 3140 | de | LND | Chel |  |  |  | N02Ц |  |  |
| EN27314020 |  | CA31 Warehouse SK3102 - Check KM drwgs Auxiliary Structures |  | 25d | 2010-10-25 A | 2010-11-29 A | EN27314015 | 100% |  |  | EN27314020 | EN27314020 | 87B | 31 | N02Ц | 200 |  | E | N | EN27 | 3140 | de | LND | LND |  |  |  | N02Ц |  |  |
| EN683140 |  | CA31 Warehouse SK3102 - Grating Fabrication drwgs |  | 30d | 2010-10-25 A | 2010-12-06 A | EN673140, EN283140 SS, EN643140 | 100% |  |  | EN683140 | EN683140 | 87B | 31 | N02Ц | 200 | C | E | N | EN68 | 3140 | de | LND | Chel |  |  | 200 | N02Ц |  |  |
| EN27314010 |  | CA31 Warehouse SK3102 - Check KM drwgs Roof Girders |  | 10d | 2011-01-10 A | 2011-01-21 A | EN27314005 | 100% | start on 2011-01-10 |  | EN27314010 | EN27314010 | 87B | 31 | N02Ц | 200 |  | E | N | EN27 | 3140 | de | LND | LND |  |  |  | N02Ц |  |  |
| EN27314030 |  | CA31 Warehouse SK3102 - Check KM drwgs Cladding |  | 25d | 2011-02-14 A | 2011-03-18 A | EN27314025 | 100% | start on 2011-02-14 |  | EN27314030 | EN27314030 | 87B | 31 | N02Ц | 200 |  | E | N | EN27 | 3140 | de | LND | LND |  |  |  | N02Ц |  |  |
| EN283140 |  | CA31 Warehouse SK3102 - Shop dwgs(KMD) by Vendor |  | 30d | 2011-02-21 A | 2011-04-01 A | EN27314030 FF+10d, EN27314010 FF+22d, EN27314020 FF+10d | 100% |  |  | EN283140 | EN283140 | 87B | 31 | N02Ц | 200 |  | E | N | EN28 | 3140 | de | LND | Chel |  |  |  | N02Ц |  |  |

Notes:
- EC423140: P3 Activity Log Info: fixed Layout
- EC443140: P3 Activity Log Info: incl. PMT approval
- EC221340: P3 Activity Log Info: TKB-B Keyplan to Subcontractor
- EC45314005: P3 Activity Log Info: incl. PMT approval
- EC45314010: P3 Activity Log Info: incl. PMT approval
- EC45314015: P3 Activity Log Info: incl. PMT approval

| ID | WBS | Activity | Type | Duration | Start | Finish | Predecessors | Complete | Resources | UDF_SAVE ACTID | UDF_SAVE ACT ID | Department | Constr. Area | Inquiry/Order No | PMT-Area | PMT-Schedule Org | PMT-Discipline | PMT-Phase | PMT-Respons. | WBS Phase | WBS Discipline | WBS Type of Work | WBS Objects | IMS | UPT | TB26 Ressource Budget | Pro Unit/DocCode |
| --- | --- | --- | --- | --- | --- | --- | --- | --- | --- | --- | --- | --- | --- | --- | --- | --- | --- | --- | --- | --- | --- | --- | --- | --- | --- | --- | --- |
|  | H | **H HVAC** |  |  | 2008-10-06 | 2010-10-28 |  |  |  |  |  |  |  |  |  |  |  |  |  |  |  |  |  |  |  |  |  |
| EH203140 |  | CA31 Warehouse - HVAC&Plumbing / Feed/Basic |  | 175d | 2008-10-06 A | 2009-06-23 A | AD2230 FF+20d | 100% |  | EH203140 | EH203140 | 87C | 31 | 999 | 200 | 200 | 035 | E | LND | E | H | EH20 | 3140 | OTH | LND |  |  |
| EH30314005 |  | CA31 Warehouse - HVAC Layouts Dwgs AFC |  | 290d | 2009-08-31 A | 2010-10-21 A | P3C00D FS+10d, EH203140 | 100% | TKB-H [640 h] | EH30314005 | EH30314005 | 87C | 31 |  | 200 | 200 | 035 | E | LNK | E | H | EH30 | 3140 | OTH | LND | 640,00 | 3102H23 |
| EH40314005 |  | CA31 Warehouse - HVAC Calculations&Flow Diagrams |  | 290d | 2009-08-31 A | 2010-10-21 A | EH30314005 SS | 100% | TKB-H [320 h] | EH40314005 | EH40314005 | 87C | 31 |  | 200 | 200 | 035 | E | LNK | E | H | EH40 | 3140 | OTH | LND | 320,00 | 3102H22 |
| EH073140 |  | CA31 Warehouse - Issue of Dwgs&Doc's by RDI | level of effort | 240d | 2009-11-09 A | 2010-10-21 A | EH40314010 FF, EH30314005 FF, EH30314005 SS+50d | 100% | TKB-H [7112 h] | EH073140 | EH073140 | 87C | 31 |  | 200 | 200 | 035 | E | LNK | E | H | EH30 | 3140 | OTH | LND | 7112,00 |  |
| EH30314010 |  | CA31 Warehouse - HVAC Layouts Dwgs IFC | milestone | 0d | 2010-04-16 A | 2010-04-16 A | EH30314005 FF-20d | 100% |  | EH30314010 | EH30314010 | 87C | 31 |  | 200 | 200 | 035 | E | LNK | E | H | EH30 | 3140 | OTH | LND |  |  |
| EH40314010 |  | CA31 Warehouse - HVAC Calc./Diagrams IFC | milestone | 0d | 2010-04-16 A | 2010-04-16 A | EH40314005 FF-19d | 100% |  | EH40314010 | EH40314010 | 87C | 31 |  | 200 | 200 | 035 | E | LNK | E | H | EH40 | 3140 | OTH | LND |  |  |
| EH30314015 |  | CA31 Warehouse - Review HVAC Layout Dwgs |  | 137d | 2010-04-19 A | 2010-10-28 A | EH30314010 | 100% | TKB-H [640 h] | EH30314015 | EH30314015 | 87C | 31 |  | 200 | 200 | 035 | E | LND | E | H | EH30 | 3140 | OTH | LND | 640,00 |  |
| EH053140 |  | CA31 Warehouse - Final Loads f.Civil/StrSteel | milestone | 0d | 2010-10-21 A | 2010-10-21 A | E3H0150 SF, EH30314005 FF | 100% |  | EH053140 | EH053140 | 87C | 31 | 999 | 200 |  |  |  | LNK | E | H | EH12 | 3140 | OTH | LND |  |  |
| EH243140 |  | CA31 Warehouse - Wall & Floor open.details | milestone | 0d | 2010-10-21 A | 2010-10-21 A | EH053140 FF, E3H0150 SF | 100% |  | EH243140 | EH243140 | 87C | 31 | 999 | 200 | 200 | 035 | E | LNK | E | H | EH24 | 3140 | OTH | LND |  | 3102H21 |
|  | B | **B Mechanical - Stationary Equipment** |  |  | 2009-08-03 | 2009-08-03 |  |  |  |  |  |  |  |  |  |  |  |  |  |  |  |  |  |  |  |  |  |
| EB053140 |  | CA31 Warehouse - Final Loads for Struc Steel | milestone | 0d | 2009-08-03 A | 2009-08-03 A | E3U0710 FF | 100% |  | EB053140 | EB053140 | 869 | 31 | 999 | 200 |  |  |  | LND | E | B | EB05 | 3140 | 3 | LND |  |  |
|  | M | **M Mechanical - Rotating Equipment** |  |  | 2009-08-03 | 2009-08-03 |  |  |  |  |  |  |  |  |  |  |  |  |  |  |  |  |  |  |  |  |  |
| EM053140 |  | CA31 Warehouse - Final Loads for Struc Steel | milestone | 0d | 2009-08-03 A | 2009-08-03 A | E3U0710 FF | 100% |  | EM053140 | EM053140 | 867 | 31 | 999 | 200 |  |  |  | LND | E | M | EM05 | 3140 | I | LND |  |  |
|  | R | **R Piping** |  |  | 2008-04-01 | 2011-01-14 |  |  |  |  |  |  |  |  |  |  |  |  |  |  |  |  |  |  |  |  |  |
| ER153140 |  | CA31 Warehouse - Conceptual Piping |  | 169d | 2008-04-01 A | 2008-11-28 A | F2760 | 100% |  | ER153140 | ER153140 | 876 | 31 | 999 | 200 |  |  |  | LNZ | E | R | ER15 | 3140 | PL | LND |  |  |
| ER303140 |  | CA31 Warehouse - CAD Model Piping / Eqpt |  | 489d | 2008-07-01 A | 2010-06-15 A | ER153140 SS, ER393140 FF+15d | 100% |  | ER303140 | ER303140 | 876 | 31 | 999 | 200 |  |  |  | LND | E | R | ER30 | 3140 | PL | LND |  |  |
| ER163140 |  | CA31 Warehouse - prel Loads for Steel Struc |  | 14d | 2008-09-22 A | 2008-10-10 A | ER153140 FF | 100% |  | ER163140 | ER163140 | 876 | 31 | 999 | 200 |  |  |  | LNZ | E | R | ER16 | 3140 | PL | LND |  |  |
| ER363140 |  | CA31 Warehouse - CAD Model Review 60% |  | 10d | 2009-10-14 A | 2009-10-27 A | F4035 FF | 100% |  | ER363140 | ER363140 | 876 | 31 | 999 | 200 |  |  |  | LND | E | R | ER36 | 3140 | 2 | LND |  |  |
| ER423140 |  | CA31 Warehouse - Stress Calculation |  | 70d | 2009-11-16 A | 2010-02-26 A | ER363140 | 100% |  | ER423140 | ER423140 | 872 | 31 | 999 | 200 |  |  |  | LND | E | R | ER42 | 3140 | PL | LND |  |  |
| ER193140 |  | CA31 Warehouse - Final Loads for Civil | milestone | 0d | 2009-11-17 A | 2009-11-17 A | ER193110 FF+5d, EC463140 SF-30d, ER163140 FF | 100% |  | ER193140 | ER193140 | 876 | 31 | 999 | 200 |  |  |  | LND | E | R | ER19 | 3140 | PL | LND |  |  |
| ER393140 |  | CA31 Warehouse - CAD Model Review 90% |  | 10d | 2010-04-26 A | 2010-05-07 A | F9250 SS | 100% |  | ER393140 | ER393140 | 876 | 31 | 999 | 200 |  |  |  | LND | E | R | ER39 | 3140 | 3 | LND |  |  |
| ER453140 |  | CA31 Warehouse - Piping Isometrics |  | 141d | 2010-06-03 A | 2010-12-17 A | ER393140 FS+10d, ER453130 SS, ER303140 FF+20d, A1KL0025, ER423140 | 100% |  | ER453140 | ER453140 | 876 | 31 | 999 | 200 |  |  |  | LND | E | R | ER45 | 3140 | 5 | LND |  |  |
| ER45314005 |  | CA31 Warehouse - Piping Isometrics (ZEP) |  | 141d | 2010-06-03 A | 2010-12-17 A | ER45313005 SS, ER423140, ER303140 FF+20d, ER393140 FS+10d | 100% |  | ER45314005 | ER45314005 | 876 | 31 | 999 | 200 |  |  |  | ZEP | E | R | ER45 | 3140 | 5 | LND |  |  |
| ER493140 |  | CA31 Warehouse - Design Check / Rel.Isos & BOM |  | 119d | 2010-07-29 A | 2011-01-14 A | ER453140 SS+40d, ER45314005 SS+40d | 100% |  | ER493140 | ER493140 | 876 | 31 | 999 | 200 |  |  |  | LND | E | R | ER49 | 3140 | 5 | LND |  |  |
| ER49314005 |  | CA31 Warehouse - Design Check/Rel.Isos&BOM ZEP |  | 119d | 2010-07-29 A | 2011-01-14 A | ER45314005 SS+40d, ER453140 SS+40d | 100% |  | ER49314005 | ER49314005 | 876 | 31 | 999 | 200 |  |  |  | ZEP | E | R | ER49 | 3140 | 5 | LND |  |  |
| ER443140 |  | CA31 Warehouse - Piping Isometrics (UG) |  | 31d | 2010-09-24 A | 2010-11-05 A | EC303140 SS+20d, ER440000 SS | 100% |  | ER443140 | ER443140 | 876 | 31 | 999 | 200 | 200 |  | E | LND | E | R | ER44 | 3140 | 4 | LND |  |  |

| ID | WBS | Activity | Type | Duration | Start | Finish | Predecessors | Complete | Resources | UDF_SAVE ACTID | UDF_SAVE ACT ID | Department | Constr. Area | Inquiry/Order No | PMT-Phase | PMT-Respons. | WBS Phase | WBS Discipline | WBS Type of Work | WBS Objects | IMS | UPT | Pro Unit/DocCode | PMT-Area | PMT-Schedule Org | TB26 Ressource Budget | Zeigen/n. Zeigen |
| --- | --- | --- | --- | --- | --- | --- | --- | --- | --- | --- | --- | --- | --- | --- | --- | --- | --- | --- | --- | --- | --- | --- | --- | --- | --- | --- | --- |
|  | E | **E Electrical** |  |  | 2008-10-06 | 2010-06-04 |  |  |  |  |  |  |  |  |  |  |  |  |  |  |  |  |  |  |  |  |  |
| EE46314005 |  | CA31 Warehouse - prelim Loads f.Civil / StrSteel |  | 15d | 2008-10-06 A | 2008-10-24 A | F3060 FF | 100% |  | EE46314005 | EE46314005 | 874 | 31 | 999 | E | LND | E | E | EE11 | 3140 | E | LND |  |  |  |  |  |
| EE903140 |  | CA31 Warehouse - Earthing Details |  | 30d | 2009-02-23 A | 2009-04-03 A | EE903110 SS | 100% |  | EE903140 | EE903140 | 874 | 31 | 999 | E | LND | E | E | EE90 | 3140 | E | LND |  |  |  |  |  |
| EE46314008 |  | CA31 Warehouse - Final Loads f.Civil / StrSteel |  | 20d | 2009-10-19 A | 2009-11-13 A | EE46314005 | 100% |  | EE46314008 | EE46314008 | 874 | 31 | 999 | E | LND | E | E | EE12 | 3140 | E | LND |  |  |  |  |  |
| EE46314010 |  | CA31 Warehouse - El. CableTray Layout Pl. / LOP's 1st Issue |  | 104d | 2009-12-07 A | 2010-05-07 A | EE460000, F4035 FS+80d | 100% |  | EE46314010 | EE46314010 | 874 | 31 | 999 | E | LND | E | E | EE46 | 3140 | E | LND |  |  |  |  |  |
| EE563140 |  | CA31 Warehouse - Cable Pulling Details |  | 119d | 2009-12-10 A | 2010-06-04 A | EE46314010 FF, EE500130 | 100% |  | EE563140 | EE563140 | 874 | 31 | 999 | E | LND | E | E | EE56 | 3140 | E | LND |  |  |  |  |  |
|  | J | **J Instrumentation** |  |  | 2008-10-06 | 2010-11-26 |  |  |  |  |  |  |  |  |  |  |  |  |  |  |  |  |  |  |  |  |  |
| EJ46314005 |  | CA31 Warehouse - prelim Loads f.Civil / StrSteel |  | 15d | 2008-10-06 A | 2008-10-24 A | F3060 FF | 100% |  | EJ46314005 | EJ46314005 | 86E | 31 | 999 | E | LND | E | J | EJ11 | 3140 | I | LND | 999 |  |  |  |  |
| EJ46314008 |  | CA31 Warehouse - Final Loads f.Civil / StrSteel |  | 10d | 2009-11-02 A | 2009-11-13 A | EJ46314005 | 100% |  | EJ46314008 | EJ46314008 | 86E | 31 | 999 | E | LND | E | J | EJ12 | 3140 | I | LND | 999 |  |  |  |  |
| EJ363140 |  | CA31 Warehouse - Hook-Up drwgs 1st Issue |  | 100d | 2010-01-18 A | 2010-06-10 A | F4035 FS+50d, A1EJ0080 | 100% |  | EJ363140 | EJ363140 | 86E | 31 | 999 | C | LEI | E | J | EJ36 | 3140 | I | LND | 999 | 200 | 200 |  |  |
| EJ46314010 |  | CA31 Warehouse - Instr Cable Tray Layout Plans 1st Issue |  | 48d | 2010-03-01 A | 2010-05-07 A | F4035 FF+65d, F9250 FS+10d, EE46314010 FF | 100% |  | EJ46314010 | EJ46314010 | 86E | 31 | 999 | E | LEI | E | J | EJ41 | 3140 | I | LND | 999 |  |  |  |  |
| EJ323140 |  | CA31 Warehouse - JB Location drwgs |  | 53d | 2010-05-26 A | 2010-08-06 A | F9250 FF+35d, F4035 | 100% |  | EJ323140 | EJ323140 | 86E | 31 | 999 | C | ZEP | E | J | EJ37 | 3140 | I | LND | 999 | 200 | 200 |  |  |
| EJ803140 |  | CA31 Warehouse - Loop Diagrams |  | 70d | 2010-08-20 A | 2010-11-26 A | A1EJ0040, EJ800010 | 100% |  | EJ803140 | EJ803140 | 86E | 31 | 999 | E | LEI | E | J | EJ80 | 3140 | I | LND | 999 |  |  |  |  |
|  | 51 | **51 CA51 - Piperack (btw. CA11-15/17/19/52/53/54)** |  |  | 2008-03-03 | 2011-03-28 |  |  |  |  |  |  |  |  |  |  |  |  |  |  |  |  |  |  |  |  |  |
|  | 5101 | **5101 Pipe Rack 1 - Part 1 - CA51** |  |  | 2008-03-03 | 2011-03-28 |  |  |  |  |  |  |  |  |  |  |  |  |  |  |  |  |  |  |  |  |  |
|  | C | **C Civil** |  |  | 2009-12-15 | 2010-09-21 |  |  |  |  |  |  |  |  |  |  |  |  |  |  |  |  |  |  |  |  |  |
| EC225101 |  | CA51 SR5101 - Layout Drwg / Loads IFD |  | 10d | 2009-12-15 A | 2009-12-30 A | EN255101 FF | 100% |  | EC225101 | EC225101 | 87A | 51 |  | E | LND | E | C | EC22 | 5101 | de | LND |  | 200 | 200 |  |  |
| EC075100 |  | CA51 SR5101 - Check & Release of working drwgs (AFC) |  | 176d | 2010-01-04 A | 2010-09-10 A | EC28510406 FF+5d | 100% | TKB-B [1080 h] | EC075100 | EC075100 | 87A | 51 | 999 | E | LND | E | C | EC07 | 5101 | cq | LND |  | 200 |  | 1080,00 | FL |
| EC265101 |  | CA51 SR5101 - Civil Static Calc Fdtn |  | 178d | 2010-01-11 A | 2010-09-21 A | P3C0BD FS+10d, EC225101, EC265103 SS | 100% |  | EC265101 | EC265101 | 87A | 51 |  | E | IPR | E | C | EC26 | 5101 | de | LND | 5101C14 | 200 | 200 |  |  |
| EC155101 |  | CA51 SR5101 - Piling drwgs AFC |  | 37d | 2010-01-18 A | 2010-03-09 A | EC265101 SS+5d | 100% |  | EC155101 | EC155101 | 87A | 51 |  |  | IPR | E | C | EC15 | 5101 | PI | LND | 5101C16 | 200 |  |  |  |
| EC285101 |  | CA51 SR5101 - Formw/Reinforce drwgs Found. AFC |  | 61d | 2010-02-08 A | 2010-05-05 A | EC155101 SS+15d, EC265101 SS+15d, EC28510105 SS | 100% |  | EC285101 | EC285101 | 87A | 51 |  | E | IPR | E | C | EC28 | 5101 | cq | LND | 5101C21 | 200 | 200 |  |  |
| EC28510105 |  | CA51 SR5101 - Precast Layout drwgs AFC |  | 116d | 2010-02-08 A | 2010-07-23 A | EC155101 SS+15d | 100% |  | EC28510105 | EC28510105 | 87A | 51 |  | E | IPR | E | C | EC28 | 5101 | PRE | LND | 5101C31 | 200 | 200 |  |  |
| EC075105 |  | CA51 SR5100 - Issue of working drwgs (AFC) by RDI |  | 138d | 2010-02-15 A | 2010-08-31 A | EC28510106 FF | 100% | TKB-B [7680 h] | EC075105 | EC075105 | 87A | 51 | 999 | E | IPR | E | C | EC07 | 5101 | cq | LND | 1010C13 | 200 |  | 7680,00 | FL |
| EC28510106 |  | CA51 SR5101 - Precast Formw/Reinf. drwgs AFC |  | 111d | 2010-02-15 A | 2010-07-23 A | EC28510105 FF | 100% |  | EC28510106 | EC28510106 | 87A | 51 |  | E | IPR | E | C | EC28 | 5101 | PRE | LND | 5101C53 | 200 | 200 |  |  |
| EC45510110 |  | CA51 SR5101 - Civil Layout drwgs IFC | milestone | 0d | 2010-03-19 A | 2010-03-19 A | EC285101 FS-30d | 100% |  | EC45510110 | EC45510110 | 87A | 51 |  | E | IPR | E | C | EC45 | 5101 | ar | LND |  | 200 |  |  |  |
| EC45510115 |  | CA51 SR5101 - Review Civil Layout drwgs |  | 28d | 2010-03-22 A | 2010-04-30 A | EC45510110 | 100% |  | EC45510115 | EC45510115 | 87A | 51 |  | E | LND | E | C | EC45 | 5101 | ar | LND |  | 200 |  |  |  |

Notes:
- EC225101: P3 Activity Log Info: TKB-B Keyplan to Subcontractor
- EC45510110: P3 Activity Log Info: incl. PMT approval
- EC45510115: P3 Activity Log Info: incl. PMT approval

| ID | WBS | Activity | Type | Duration | Start | Finish | Predecessors | Complete | Resources | UDF_SAVE ACTID | UDF_SAVE ACT ID | Department | Type of Work | Constr. Area | Inquiry/Order No | PMT-Area | PMT-Schedule Org | PMT-Discipline | PMT-Phase | PMT-Respons. | Zeigen/n. Zeigen | WBS Phase | WBS Discipline | WBS Type of Work | WBS Objects | IMS | UPT | TB26 Ressource Budget |
| --- | --- | --- | --- | --- | --- | --- | --- | --- | --- | --- | --- | --- | --- | --- | --- | --- | --- | --- | --- | --- | --- | --- | --- | --- | --- | --- | --- | --- |
|  | N | **N Structural Steel** |  |  | 2008-03-03 | 2010-11-22 |  |  |  |  |  |  |  |  |  |  |  |  |  |  |  |  |  |  |  |  |  |  |
| EN155101 |  | CA51 SR5101 - CAD Model/Concepts StrSteel |  | 126d | 2008-03-03 A | 2008-08-29 A | EN155102 FF | 100% |  | EN155101 | EN155101 | 87B | N01A | 51 | N01A | 200 | 200 | 055 | E | LND | 0 | E | N | EN15 | 5101 | de | LND |  |
| EN21510105 |  | CA51 SR5101 - GA-Drwgs + Fdtn Loads |  | 119.25d | 2009-02-09 A | 2009-07-31 A | EJ46510105, ER165101, EN155101 FF-1d, EE46510105, AD2230 FS+30d | 100% |  | EN21510105 | EN21510105 | 87B | N01A | 51 | N01A | 200 |  |  |  | LND |  | E | N | EN21 | 5101 | de | LND |  |
| EN24510105 |  | CA51 SR5101 - Static Calc for Fdtn Loads |  | 33.75d | 2009-08-14 A | 2009-09-30 A | EN21510105 FS+10d | 100% |  | EN24510105 | EN24510105 | 87B | N01A | 51 | N01A | 200 |  |  |  | LND |  | E | N | EN24 | 5101 | de | LND |  |
| EN255101 |  | CA51 SR5101 - Loads for Civil | milestone | 0d | 2009-11-11 A | 2009-11-11 A | EN24510105 FF+31d | 100% |  | EN255101 | EN255101 | 87B | N01A | 51 | N01A | 200 | 200 | 055 | E | LND | 0 | E | N | EN25 | 5101 | de | LND |  |
| EN21510110 |  | CA51 SR5101 - GA-Drwgs + Final Loads |  | 84d | 2009-12-07 A | 2010-04-09 A | EN24510105 FS+10d, EE46510108 FF, EJ46510108 FF, F4030 FS+41d, EN21510105, ER425101 | 100% | TKB-S [480 h] | EN21510110 | EN21510110 | 87B | N01A | 51 | N01A | 200 |  |  |  | LEI |  | E | N | EN21 | 5101 | de | LND | 480,00 |
| EN24510110 |  | CA51 SR5101 - Final Static Calc |  | 103d | 2009-12-21 A | 2010-05-21 A | ER195101 FF, EN21510110 FF+10d | 100% | TKB-S [480 h] | EN24510110 | EN24510110 | 87B | N01A | 51 | N01A | 200 |  |  |  | LEI |  | E | N | EN24 | 5101 | de | LND | 480,00 |
| EN265101 |  | CA51 SR5101 - Layout dwgs input for KM dwgs |  | 32d | 2010-04-20 A | 2010-06-04 A | EN24510110 FF+7d, F4030 FF+20d | 100% | TKB-S [880 h] | EN265101 | EN265101 | 87B | N01A | 51 | N01A | 200 |  |  |  | LEI |  | E | N | EN26 | 5101 | st | LND | 880,00 |
| EN675101 |  | CA51 SR5101 - Grating Cut-Out drwgs |  | 68d | 2010-05-28 A | 2010-08-31 A | EN265101 FS+10d, EN27510110, ER425101 FF | 100% | TKB-S [320 h] | EN675101 | EN675101 | 87B | N01A | 51 | N01A | 200 | 200 |  | C | LEI |  | E | N | EN67 | 5101 | de | LND | 320,00 |
| EN645101 |  | CA51 SR5101 - Check Grating Cut-Out drwgs |  | 12d | 2010-06-15 A | 2010-06-30 A | EN675101 | 100% |  | EN645101 | EN645101 | 87B | N01A | 51 | N01A | 200 | 200 |  | C | LEI |  | E | N | EN67 | 5101 | de | LND |  |
| EN27510105 |  | CA51 SR5101 - KM drwgs |  | 34d | 2010-07-07 A | 2010-08-23 A | EN24510105, EN265101, P3N01D | 100% | KM Drwgs preparation by Cheljabinsk [95 t] | EN27510105 | EN27510105 | 87B | N01A | 51 | N01A | 200 |  |  |  | Chel |  | E | N | EN27 | 5101 | de | LND | 0,00 |
| EN685101 |  | CA51 SR5101 - Grating Fabrication drwgs |  | 20d | 2010-08-16 A | 2010-09-10 A | EN675101, EN645101 | 100% |  | EN685101 | EN685101 | 87B | N01A | 51 | N01A | 200 | 200 |  | C | Chel |  | E | N | EN68 | 5101 | de | LND |  |
| EN27510110 |  | CA51 SR5101 - Check KM drwgs |  | 14d | 2010-08-24 A | 2010-09-10 A | EN27510105 | 100% |  | EN27510110 | EN27510110 | 87B | N01A | 51 | N01A | 200 |  |  |  | LEI |  | E | N | EN27 | 5101 | de | LND |  |
| EN285101 |  | CA51 SR5101 - Shop dwgs(KMD) by Vendor |  | 50d | 2010-09-13 A | 2010-11-22 A | EN27510110 | 100% |  | EN285101 | EN285101 | 87B | N01A | 51 | N01A | 200 |  |  |  | Chel |  | E | N | EN28 | 5101 | de | LND |  |
|  | R | **R Piping** |  |  | 2008-04-01 | 2011-03-28 |  |  |  |  |  |  |  |  |  |  |  |  |  |  |  |  |  |  |  |  |  |  |
| ER155101 |  | CA51 SR5101 - Conceptual Piping |  | 169d | 2008-04-01 A | 2008-11-28 A | ER155102 FF | 100% |  | ER155101 | ER155101 | 876 |  | 51 |  | 200 |  |  |  | LND |  | E | R | ER15 | 5101 | PL | LND |  |
| ER305101 |  | CA51 SR5101 - CAD Model Piping / Equipment |  | 531d | 2008-05-02 A | 2010-06-16 A | ER155101 SS, ER365102 FF+10d | 100% |  | ER305101 | ER305101 | 876 |  | 51 |  | 200 |  |  |  | LNI |  | E | R | ER30 | 5101 | PL | LND |  |
| ER165101 |  | CA51 SR5101 - prelim Loads for Struc Steel |  | 20d | 2009-01-05 A | 2009-01-30 A | ER155101 FF | 100% |  | ER165101 | ER165101 | 876 |  | 51 |  | 200 |  |  |  | LND |  | E | R | ER16 | 5101 | PL | LND |  |
| ER365101 |  | CA51 SR5101 - CAD Model Review 60% |  | 12d | 2009-11-02 A | 2009-11-17 A | F4030 SS | 100% |  | ER365101 | ER365101 | 876 |  | 51 |  | 200 |  |  |  | LND |  | E | R | ER36 | 5101 | 2 | LND |  |
| ER425101 |  | CA51 SR5101 - Stress Calculation / Final Loads |  | 98d | 2009-11-16 A | 2010-04-09 A | F4030 FF | 100% |  | ER425101 | ER425101 | 872 |  | 51 |  | 200 |  |  |  | LND |  | E | R | ER42 | 5101 | PL | LND |  |
| ER195101 |  | CA51 SR5101 - Final Loads for Struc Steel | milestone | 0d | 2009-11-26 A | 2009-11-26 A | EN21510110 FF-5d, F4030 FF, ER165101 FF | 100% |  | ER195101 | ER195101 | 876 |  | 51 |  | 200 |  |  |  | LNI |  | E | R | ER19 | 5101 | PL | LND |  |
| ER395101 |  | CA51 SR5101 - CAD Model Review 90% |  | 10d | 2010-06-28 A | 2010-07-09 A | ER365101, F4460 FF | 100% |  | ER395101 | ER395101 | 876 |  | 51 |  | 200 |  |  |  | LND |  | E | R | ER39 | 5101 | 3 | LND |  |
| ER455101 |  | CA51 SR5101 - Piping Isometrics |  | 104d | 2010-06-28 A | 2010-11-19 A | ER395101 FF+20d, ER305101 FF, ER425101, A1KL0025 | 100% |  | ER455101 | ER455101 | 876 |  | 51 |  | 200 |  |  |  | LEI |  | E | R | ER45 | 5101 | 5 | LND |  |
| ER495101 |  | CA51 SR5101 - Design Check / Release Isos & BOM |  | 173d | 2010-07-26 A | 2011-03-28 A | ER455101 FF, EL20050 SF | 100% |  | ER495101 | ER495101 | 876 |  | 51 |  | 200 |  |  |  | LEI |  | E | R | ER49 | 5101 | 5 | LND |  |
| ER475101 |  | CA51 SR5101 - Piping Layout drwgs |  | 69d | 2010-09-17 A | 2010-12-23 A | ER395101 FF+20d, ER305101 | 100% |  | ER475101 | ER475101 | 876 |  | 51 |  | 200 |  |  |  | LEI |  | E | R | ER47 | 5101 | 5 | LND |  |
| ER445101 |  | CA51 SR5101 - Piping Isometrics (UG) |  | 25d | 2010-10-04 A | 2010-11-05 A | ER440000 FF, EC305101 SS+20d | 100% |  | ER445101 | ER445101 | 876 |  | 51 |  | 200 | 200 |  | E | LND |  | E | R | ER44 | 5101 | 4 | LND |  |

| ID | WBS | Activity | Type | Duration | Start | Finish | Predecessors | Complete | Resources | UDF_SAVE ACTID | UDF_SAVE ACT ID | Department | Constr. Area | PMT-Phase | PMT-Respons. | WBS Phase | WBS Discipline | WBS Type of Work | WBS Objects | IMS | UPT | TB26 Ressource Budget | Pro Unit/DocCode | PMT-Area | PMT-Schedule Org |
| --- | --- | --- | --- | --- | --- | --- | --- | --- | --- | --- | --- | --- | --- | --- | --- | --- | --- | --- | --- | --- | --- | --- | --- | --- | --- |
|  | E | **E Electrical** |  |  | 2008-10-06 | 2011-02-22 |  |  |  |  |  |  |  |  |  |  |  |  |  |  |  |  |  |  |  |
| EE46510105 |  | CA51 SR5101 - prelim Loads for Struc Steel |  | 10d | 2008-10-06 A | 2008-10-17 A | F3060 FF | 100% |  | EE46510105 | EE46510105 | 874 | 51 | E | LND | E | E | EE11 | 5101 | E | LND |  |  |  |  |
| EE905101 |  | CA51 SR5101 - Earthing Details |  | 30d | 2009-05-07 A | 2009-06-19 A | EE901201 SS | 100% |  | EE905101 | EE905101 | 874 | 51 | E | LND | E | E | EE90 | 5101 | E | LND |  |  |  |  |
| EE46510108 |  | CA51 SR5101 - Final Loads for Struc Steel |  | 40d | 2009-12-01 A | 2010-01-29 A | EE46510105 | 100% |  | EE46510108 | EE46510108 | 874 | 51 | E | LEI | E | E | EE12 | 5101 | E | LND |  |  |  |  |
| EE565101 |  | CA51 SR5101 - Cable Pulling Details |  | 164d | 2009-12-03 A | 2010-07-30 A | EE46510110 FF, EE500130 | 100% |  | EE565101 | EE565101 | 874 | 51 | E | LEI | E | E | EE56 | 5101 | E | LND |  |  |  |  |
| EE46510110 |  | CA51 SR5101 - El. CableTray Layout Pl. 1st Issue |  | 172d | 2009-12-07 A | 2010-08-13 A | EE460000, F4030 FS+20d | 100% |  | EE46510110 | EE46510110 | 874 | 51 | E | LEI | E | E | EE46 | 5101 | E | LND |  |  |  |  |
| EE765101 |  | CA51 SR5101 PR - Layout Plan Light.& Sockets 1st Issue |  | 140d | 2010-01-26 A | 2010-08-13 A | EE000180 FS+10d | 100% | TAE [3904 h] | EE765101 | EE765101 | 874 | 51 | E | LEI | E | E | EE76 | 5101 | E | LND | 3904,00 |  |  |  |
| EE76111010 |  | CA11 - Layout Plan Light.& Sockets final Issue |  | 83d | 2010-08-24 A | 2010-12-17 A | EE761110, EE761111, F4460 FS+30d | 100% | TAE [800 h] | EE76111010 | EE76111010 | 874 | 51 | E | LEI | E | E | EE76 | 5101 | E | LND | 800,00 |  |  |  |
| EE76120010 |  | CA12 - Layout Plan Light.& Sockets final Issue |  | 103d | 2010-08-24 A | 2011-01-18 A | EE761200, EE761222, F4460 FS+30d, EE761221 | 100% | TAE [1600 h] | EE76120010 | EE76120010 | 874 | 51 | E | LEI | E | E | EE76 | 5101 | E | LND | 1600,00 |  |  |  |
| EE76130010 |  | CA13 - Layout Plan Light.& Sockets final Issue |  | 103d | 2010-08-24 A | 2011-01-18 A | EE761321, EE761322, F4460 FS+30d, EE761300 | 100% | TAE [1600 h] | EE76130010 | EE76130010 | 874 | 51 | E | LEI | E | E | EE76 | 5101 | E | LND | 1600,00 |  |  |  |
| EE46510120 |  | All Areas - El. CableTray Layout Pl. final Issue |  | 87d | 2010-09-20 A | 2011-01-21 A | F4460, F9250, F4462 | 100% | TAE [1600 h] | EE46510120 | EE46510120 | 874 | 51 | E | LEI | E | E | EE46 | 5101 | E | LND | 1600,00 |  |  |  |
| EE76510110 |  | PipeRacks - Layout Plan Light.& Sockets final Issue |  | 99d | 2010-09-20 A | 2011-02-08 A | F4460 FS+30d | 100% | TAE [1600 h] | EE76510110 | EE76510110 | 874 | 51 | E | LEI | E | E | EE76 | 5101 | E | LND | 1600,00 |  |  |  |
| EE76170010 |  | CA17 - Layout Plan Light.& Sockets final Issue |  | 82d | 2010-10-27 A | 2011-02-22 A | F4462, EE761700 | 100% | TAE [2400 h] | EE76170010 | EE76170010 | 874 | 51 | E | LEI | E | E | EE76 | 5101 | E | LND | 2400,00 |  |  |  |
|  | J | **J Instrumentation** |  |  | 2008-10-06 | 2010-08-13 |  |  |  |  |  |  |  |  |  |  |  |  |  |  |  |  |  |  |  |
| EJ46510105 |  | CA51 SR5101 - prelim Loads for Struc Steel |  | 15d | 2008-10-06 A | 2008-10-24 A | F3060 FF | 100% |  | EJ46510105 | EJ46510105 | 86E | 51 | E | LND | E | J | EJ11 | 5101 | I | LND |  | 999 |  |  |
| EJ46510108 |  | CA51 SR5101 - Final Loads for Struc Steel |  | 10d | 2010-02-22 A | 2010-03-05 A | EJ46510105 | 100% |  | EJ46510108 | EJ46510108 | 86E | 51 | E | LEI | E | J | EJ12 | 5101 | I | LND |  | 999 |  |  |
| EJ46510110 |  | CA51 SR5101 - Instr Cable Tray Layout Plans 1st Issue |  | 116d | 2010-03-01 A | 2010-08-13 A | F4460, F4030 FF, EE46510110 FF | 100% |  | EJ46510110 | EJ46510110 | 86E | 51 | E | LEI | E | J | EJ41 | 5101 | I | LND |  | 999 |  |  |
|  | 5102 | **5102 Pipe Rack 1 - Part 2 - CA51** |  |  | 2008-03-03 | 2011-03-28 |  |  |  |  |  |  |  |  |  |  |  |  |  |  |  |  |  |  |  |
|  | C | **C Civil** |  |  | 2009-12-15 | 2010-09-21 |  |  |  |  |  |  |  |  |  |  |  |  |  |  |  |  |  |  |  |
| EC225102 |  | CA51 SR5102 - Layout Drwg / Loads IFD |  | 10d | 2009-12-15 A | 2009-12-30 A | EN255102 FF | 100% |  | EC225102 | EC225102 | 87A | 51 |  | LND | E | C | EC22 | 5102 | de | LND |  | 5100C01 | 200 |  |
| EC265102 |  | CA51 SR5102 - Civil Static Calc Fdtn |  | 178d | 2010-01-11 A | 2010-09-21 A | EC225102, P3C0BD FS+15d | 100% |  | EC265102 | EC265102 | 87A | 51 |  | IPR | E | C | EC26 | 5102 | de | LND |  | 5102C14 | 200 |  |
| EC155102 |  | CA51 SR5102 - Piling drwgs AFC |  | 37d | 2010-01-18 A | 2010-03-09 A | EC265102 SS+5d | 100% |  | EC155102 | EC155102 | 87A | 51 |  | IPR | E | C | EC15 | 5102 | PI | LND |  | 5102C16 | 200 |  |
| EC285102 |  | CA51 SR5102 - Formw/Reinforce drwgs Found. AFC |  | 61d | 2010-02-08 A | 2010-05-05 A | EC265102 SS+15d, EC155102 SS+10d, EC28510205 SS | 100% |  | EC285102 | EC285102 | 87A | 51 | E | IPR | E | C | EC28 | 5102 | cq | LND |  | 5102C21 | 200 | 200 |
| EC28510205 |  | CA51 SR5102 - Precast Layout drwgs AFC |  | 136d | 2010-02-08 A | 2010-08-20 A | EC155102 SS+15d | 100% |  | EC28510205 | EC28510205 | 87A | 51 | E | IPR | E | C | EC28 | 5102 | PRE | LND |  | 5102C31 | 200 | 200 |
| EC45510215 |  | CA51 SR5102 - Review Civil Layout drwgs |  | 10d | 2010-02-08 A | 2010-02-19 A | EC45510210 | 100% |  | EC45510215 | EC45510215 | 87A | 51 | E | LND | E | C | EC45 | 5102 | ar | LND |  |  | 200 |  |
| EC28510206 |  | CA51 SR5102 - Precast Formw/Reinf. drwgs AFC |  | 131d | 2010-02-15 A | 2010-08-20 A | EC28510205 FF | 100% |  | EC28510206 | EC28510206 | 87A | 51 | E | IPR | E | C | EC28 | 5102 | PRE | LND |  | 5102C53 | 200 | 200 |
| EC45510210 |  | CA51 SR5102 - Civil Layout drwgs IFC | milestone | 0d | 2010-03-26 A | 2010-03-26 A | EC285102 FS-30d | 100% |  | EC45510210 | EC45510210 | 87A | 51 | E | IPR | E | C | EC45 | 5102 | ar | LND |  |  | 200 |  |

Notes:
- EC225102: P3 Activity Log Info: TKB-B Keyplan to Subcontractor
- EC45510215: P3 Activity Log Info: incl. PMT approval
- EC45510210: P3 Activity Log Info: incl. PMT approval

| ID | WBS | Activity | Type | Duration | Start | Finish | Predecessors | Complete | Resources | UDF_SAVE ACTID | UDF_SAVE ACT ID | Department | Type of Work | Constr. Area | Inquiry/Order No | PMT-Area | PMT-Schedule Org | PMT-Discipline | PMT-Phase | PMT-Respons. | Zeigen/n. Zeigen | WBS Phase | WBS Discipline | WBS Type of Work | WBS Objects | IMS | UPT | TB26 Ressource Budget |
| --- | --- | --- | --- | --- | --- | --- | --- | --- | --- | --- | --- | --- | --- | --- | --- | --- | --- | --- | --- | --- | --- | --- | --- | --- | --- | --- | --- | --- |
|  | N | **N Structural Steel** |  |  | 2008-03-03 | 2010-11-08 |  |  |  |  |  |  |  |  |  |  |  |  |  |  |  |  |  |  |  |  |  |  |
| EN155102 |  | CA51 SR5102 - CAD Model/Concepts StrSteel |  | 126d | 2008-03-03 A | 2008-08-29 A | AD2230 FF | 100% |  | EN155102 | EN155102 | 87B | N01B | 51 | N01B | 200 | 200 | 055 | E | LND | 0 | E | N | EN15 | 5102 | de | LND |  |
| EN21510205 |  | CA51 SR5102 - GA-Drwgs + Fdtn Loads |  | 97d | 2009-02-09 A | 2009-07-01 A | EE46510205, AD2230 FS+30d, EN21510105 SS, ER165102, EN155102 FF, EJ46510205 | 100% |  | EN21510205 | EN21510205 | 87B | N01B | 51 | N01B | 200 |  |  |  | LND |  | E | N | EN21 | 5102 | de | LND |  |
| EN24510205 |  | CA51 SR5102 - Static Calc for Fdtn Loads |  | 56d | 2009-07-15 A | 2009-09-30 A | EN21510205 FS+10d | 100% |  | EN24510205 | EN24510205 | 87B | N01B | 51 | N01B | 200 |  |  |  | LND |  | E | N | EN24 | 5102 | de | LND |  |
| EN255102 |  | CA51 SR5102 - Loads for Civil | milestone | 0d | 2009-11-11 A | 2009-11-11 A | EN24510205 FF+31d | 100% |  | EN255102 | EN255102 | 87B | N01B | 51 | N01B | 200 | 200 | 055 | E | LND | 0 | E | N | EN25 | 5102 | de | LND |  |
| EN21510210 |  | CA51 SR5102 - GA-Drwgs + Final Loads |  | 89d | 2009-12-07 A | 2010-04-16 A | EJ46510208 FF, EN21510205, EN24510205, F4030 FS+10d, ER425102, EE46510208 FF | 100% | TKB-S [480 h] | EN21510210 | EN21510210 | 87B | N01B | 51 | N01B | 200 |  |  |  | LEI |  | E | N | EN21 | 5102 | de | LND | 480,00 |
| EN24510210 |  | CA51 SR5102 - Final Static Calc |  | 114d | 2009-12-21 A | 2010-06-08 A | EN21510210, ER195102 FF | 100% | TKB-S [480 h] | EN24510210 | EN24510210 | 87B | N01B | 51 | N01B | 200 |  |  |  | LEI |  | E | N | EN24 | 5102 | de | LND | 480,00 |
| EN265102 |  | CA51 SR5102 - Layout dwgs input for KM dwgs |  | 47d | 2010-04-20 A | 2010-06-25 A | F4030 FF+20d, EN24510210 FF+8d | 100% | TKB-S [880 h] | EN265102 | EN265102 | 87B | N01B | 51 | N01B | 200 |  |  |  | LEI |  | E | N | EN26 | 5102 | st | LND | 880,00 |
| EN675102 |  | CA51 SR5102 - Grating Cut-Out drwgs |  | 67d | 2010-05-31 A | 2010-08-31 A | ER425102 FF, EN265102 FS+10d | 100% | TKB-S [240 h] | EN675102 | EN675102 | 87B | N01B | 51 | N01B | 200 | 200 |  | C | LEI |  | E | N | EN67 | 5102 | de | LND | 240,00 |
| EN27510205 |  | CA51 SR5102 - KM drwgs |  | 38d | 2010-07-07 A | 2010-08-27 A | P3N01D, EN24510205, EN265102 | 100% | KM Drwgs preparation by Cheljabinsk [230 t] | EN27510205 | EN27510205 | 87B | N01B | 51 | N01B | 200 |  |  |  | Chel |  | E | N | EN27 | 5102 | de | LND | 0,00 |
| EN645102 |  | CA51 SR5102 - Check Grating Cut-Out drwgs |  | 2d | 2010-08-16 A | 2010-08-17 A | EN675102 | 100% |  | EN645102 | EN645102 | 87B | N01B | 51 | N01B | 200 | 200 |  | C | LEI |  | E | N | EN67 | 5102 | de | LND |  |
| EN685102 |  | CA51 SR5102 - Grating Fabrication drwgs |  | 20d | 2010-08-18 A | 2010-09-14 A | EN645102, EN675102 | 100% |  | EN685102 | EN685102 | 87B | N01B | 51 | N01B | 200 | 200 |  | C | Chel |  | E | N | EN68 | 5102 | de | LND |  |
| EN27510210 |  | CA51 SR5102 - Check KM drwgs |  | 5d | 2010-08-30 A | 2010-09-03 A | EN27510205 | 100% |  | EN27510210 | EN27510210 | 87B | N01B | 51 | N01B | 200 |  |  |  | LEI |  | E | N | EN27 | 5102 | de | LND |  |
| EN285102 |  | CA51 SR5102 - Shop dwgs(KMD) by Vendor |  | 46d | 2010-09-06 A | 2010-11-08 A | EN27510210 | 100% |  | EN285102 | EN285102 | 87B | N01B | 51 | N01B | 200 |  |  |  | Chel |  | E | N | EN28 | 5102 | de | LND |  |
|  | R | **R Piping** |  |  | 2008-04-01 | 2011-03-28 |  |  |  |  |  |  |  |  |  |  |  |  |  |  |  |  |  |  |  |  |  |  |
| ER155102 |  | CA51 SR5102 - Conceptual Piping |  | 169d | 2008-04-01 A | 2008-11-28 A | F2760 | 100% |  | ER155102 | ER155102 | 876 |  | 51 |  | 200 |  |  |  | LND |  | E | R | ER15 | 5102 | PL | LND |  |
| ER305102 |  | CA51 SR5102 - CAD Model Piping / Equipment |  | 531d | 2008-05-02 A | 2010-06-16 A | ER155102 SS, ER365102 FF+10d | 100% |  | ER305102 | ER305102 | 876 |  | 51 |  | 200 |  |  |  | LNI |  | E | R | ER30 | 5102 | PL | LND |  |
| ER165102 |  | CA51 SR5102 - prelim Loads for Struc Steel |  | 20d | 2009-01-05 A | 2009-01-30 A | ER155102 FF | 100% |  | ER165102 | ER165102 | 876 |  | 51 |  | 200 |  |  |  | LND |  | E | R | ER16 | 5102 | PL | LND |  |
| ER365102 |  | CA51 SR5102 - CAD Model Review 60% |  | 12d | 2009-11-02 A | 2009-11-17 A | F4030 SS | 100% |  | ER365102 | ER365102 | 876 |  | 51 |  | 200 |  |  |  | LND |  | E | R | ER36 | 5102 | 2 | LND |  |
| ER425102 |  | CA51 SR5102 - Stress Calculation / Final Loads |  | 98d | 2009-11-16 A | 2010-04-09 A | F4030 FF | 100% |  | ER425102 | ER425102 | 872 |  | 51 |  | 200 |  |  |  | LND |  | E | R | ER42 | 5102 | PL | LND |  |
| ER195102 |  | CA51 SR5102 - Final Loads for Struc Steel | milestone | 0d | 2009-11-26 A | 2009-11-26 A | EN21510210 FF-5d, ER165102 FF, F4030 FF | 100% |  | ER195102 | ER195102 | 876 |  | 51 |  | 200 |  |  |  | LNI |  | E | R | ER19 | 5102 | PL | LND |  |
| ER455102 |  | CA51 SR5102 - Piping Isometrics |  | 104d | 2010-06-28 A | 2010-11-19 A | ER305102 FF, A1KL0025, ER395101 FF+20d, ER425102 | 100% |  | ER455102 | ER455102 | 876 |  | 51 |  | 200 |  |  |  | LEI |  | E | R | ER45 | 5102 | 5 | LND |  |
| ER495102 |  | CA51 SR5102 - Design Check / Release Isos & BOM |  | 173d | 2010-07-26 A | 2011-03-28 A | EL20050 SF, ER455102 FF | 100% |  | ER495102 | ER495102 | 876 |  | 51 |  | 200 |  |  |  | LEI |  | E | R | ER49 | 5102 | 5 | LND |  |
| ER475102 |  | CA51 SR5102 - Piping Layout drwgs |  | 69d | 2010-09-17 A | 2010-12-23 A | ER305102, ER475101 FF, ER395101 FF+20d | 100% |  | ER475102 | ER475102 | 876 |  | 51 |  | 200 |  |  |  | LEI |  | E | R | ER47 | 5102 | 5 | LND |  |
| ER445102 |  | CA51 SR5102 - Piping Isometrics (UG) |  | 25d | 2010-10-04 A | 2010-11-05 A | EC305102 SS+20d, ER440000 FF | 100% |  | ER445102 | ER445102 | 876 |  | 51 |  | 200 | 200 |  | E | LND |  | E | R | ER44 | 5102 | 4 | LND |  |

| ID | WBS | Activity | Type | Duration | Start | Finish | Predecessors | Complete | Resources | UDF_SAVE ACTID | UDF_SAVE ACT ID | Department | Constr. Area | PMT-Phase | PMT-Respons. | WBS Phase | WBS Discipline | WBS Type of Work | WBS Objects | IMS | UPT | Pro Unit/DocCode | PMT-Area | PMT-Schedule Org | Type of Work | Inquiry/Order No | PMT-Discipline | Zeigen/n. Zeigen | TB26 Ressource Budget |
| --- | --- | --- | --- | --- | --- | --- | --- | --- | --- | --- | --- | --- | --- | --- | --- | --- | --- | --- | --- | --- | --- | --- | --- | --- | --- | --- | --- | --- | --- |
|  | E | **E Electrical** |  |  | 2008-10-06 | 2010-08-13 |  |  |  |  |  |  |  |  |  |  |  |  |  |  |  |  |  |  |  |  |  |  |  |
| EE46510205 |  | CA51 SR5102 - prelim Loads for Struc Steel |  | 10d | 2008-10-06 A | 2008-10-17 A | F3060 FF | 100% |  | EE46510205 | EE46510205 | 874 | 51 | E | LND | E | E | EE11 | 5102 | E | LND |  |  |  |  |  |  |  |  |
| EE905102 |  | CA51 SR5102 - Earthing Details |  | 30d | 2009-05-07 A | 2009-06-19 A | EE901201 SS | 100% |  | EE905102 | EE905102 | 874 | 51 | E | LND | E | E | EE90 | 5102 | E | LND |  |  |  |  |  |  |  |  |
| EE565102 |  | CA51 SR5102 - Cable Pulling Details |  | 164d | 2009-12-03 A | 2010-07-30 A | EE46510210 FF, EE500130 | 100% |  | EE565102 | EE565102 | 874 | 51 | E | LEI | E | E | EE56 | 5102 | E | LND |  |  |  |  |  |  |  |  |
| EE46510208 |  | CA51 SR5102 - Final Loads for Struc Steel |  | 41d | 2009-12-07 A | 2010-02-05 A | EE46510205 | 100% |  | EE46510208 | EE46510208 | 874 | 51 | E | LEI | E | E | EE12 | 5102 | E | LND |  |  |  |  |  |  |  |  |
| EE46510210 |  | CA51 SR5102 - El. CableTray Layout Pl. 1st Issue |  | 172d | 2009-12-07 A | 2010-08-13 A | F4030 FF+70d, EE460000 | 100% |  | EE46510210 | EE46510210 | 874 | 51 | E | LEI | E | E | EE46 | 5102 | E | LND |  |  |  |  |  |  |  |  |
| EE765102 |  | CA51 SR5102 - Layout Plan Light.& Sockets 1st Issue |  | 140d | 2010-01-26 A | 2010-08-13 A | EE000180 FS+10d | 100% |  | EE765102 | EE765102 | 874 | 51 | E | LEI | E | E | EE76 | 5102 | E | LND |  |  |  |  |  |  |  |  |
|  | J | **J Instrumentation** |  |  | 2008-10-06 | 2010-08-13 |  |  |  |  |  |  |  |  |  |  |  |  |  |  |  |  |  |  |  |  |  |  |  |
| EJ46510205 |  | CA51 SR5102 - prelim Loads for Struc Steel |  | 15d | 2008-10-06 A | 2008-10-24 A | F3060 FF | 100% |  | EJ46510205 | EJ46510205 | 86E | 51 | E | LND | E | J | EJ11 | 5102 | I | LND | 999 |  |  |  |  |  |  |  |
| EJ46510208 |  | CA51 SR5102 - Final Loads for Struc Steel |  | 10d | 2010-02-15 A | 2010-02-26 A | EJ46510205 | 100% |  | EJ46510208 | EJ46510208 | 86E | 51 | E | LEI | E | J | EJ12 | 5102 | I | LND | 999 |  |  |  |  |  |  |  |
| EJ46510210 |  | CA51 SR5102 - Instr Cable Tray Layout Plans 1st Issue |  | 116d | 2010-03-01 A | 2010-08-13 A | F4030 FF, EE46510210 FF, F4460 | 100% |  | EJ46510210 | EJ46510210 | 86E | 51 | E | LEI | E | J | EJ41 | 5102 | I | LND | 999 |  |  |  |  |  |  |  |
|  | 5103 | **5103 Pipe Rack 1 - Part 3 - CA51** |  |  | 2008-03-03 | 2011-03-28 |  |  |  |  |  |  |  |  |  |  |  |  |  |  |  |  |  |  |  |  |  |  |  |
|  | C | **C Civil** |  |  | 2009-12-15 | 2010-09-21 |  |  |  |  |  |  |  |  |  |  |  |  |  |  |  |  |  |  |  |  |  |  |  |
| EC225103 |  | CA51 SR5103 - Layout Drwg / Loads IFD |  | 10d | 2009-12-15 A | 2009-12-30 A | EN255103 FF | 100% |  | EC225103 | EC225103 | 87A | 51 | E | LND | E | C | EC22 | 5103 | de | LND |  | 200 | 200 |  |  |  |  |  |
| EC265103 |  | CA51 SR5103 - Civil Static Calc Fdtn |  | 178d | 2010-01-11 A | 2010-09-21 A | EC265102 SS, EC225103, P3C0BD FS+10d | 100% |  | EC265103 | EC265103 | 87A | 51 | E | IPR | E | C | EC26 | 5103 | de | LND | 5103C14 | 200 | 200 |  |  |  |  |  |
| EC155103 |  | CA51 SR5103 - Piling drwgs AFC |  | 37d | 2010-01-18 A | 2010-03-09 A | EC265103 SS+5d | 100% |  | EC155103 | EC155103 | 87A | 51 |  | IPR | E | C | EC15 | 5103 | PI | LND | 5103C16 | 200 |  |  |  |  |  |  |
| EC285103 |  | CA51 SR5103 - Formw/Reinforce drwgs Found. AFC |  | 61d | 2010-02-08 A | 2010-05-05 A | EC265103 SS+15d, EC155103 SS+10d, EC28510305 SS | 100% |  | EC285103 | EC285103 | 87A | 51 | E | IPR | E | C | EC28 | 5103 | cq | LND | 5103C21 | 200 | 200 |  |  |  |  |  |
| EC28510305 |  | CA51 SR5103 - Precast Layout drwgs AFC |  | 126d | 2010-02-08 A | 2010-08-06 A | EC155103 SS+15d | 100% |  | EC28510305 | EC28510305 | 87A | 51 | E | IPR | E | C | EC28 | 5103 | PRE | LND | 5103C31 | 200 | 200 |  |  |  |  |  |
| EC45510315 |  | CA51 SR5103 - Review Civil Layout drwgs |  | 10d | 2010-02-08 A | 2010-02-19 A | EC45510310 | 100% |  | EC45510315 | EC45510315 | 87A | 51 | E | LND | E | C | EC45 | 5103 | ar | LND |  | 200 |  |  |  |  |  |  |
| EC28510306 |  | CA51 SR5103 - Precast Formw/Reinf. drwgs AFC |  | 121d | 2010-02-15 A | 2010-08-06 A | EC28510305 FF | 100% |  | EC28510306 | EC28510306 | 87A | 51 | E | IPR | E | C | EC28 | 5103 | PRE | LND | 5103C53 | 200 | 200 |  |  |  |  |  |
| EC45510310 |  | CA51 SR5103 - Civil Layout drwgs IFC | milestone | 0d | 2010-03-26 A | 2010-03-26 A | EC285103 FS-30d | 100% |  | EC45510310 | EC45510310 | 87A | 51 | E | IPR | E | C | EC45 | 5103 | ar | LND |  | 200 |  |  |  |  |  |  |
|  | N | **N Structural Steel** |  |  | 2008-03-03 | 2010-10-18 |  |  |  |  |  |  |  |  |  |  |  |  |  |  |  |  |  |  |  |  |  |  |  |
| EN155103 |  | CA51 SR5103 - CAD Model/Concepts StrSteel |  | 126d | 2008-03-03 A | 2008-08-29 A | AD2230 FF | 100% |  | EN155103 | EN155103 | 87B | 51 | E | LND | E | N | EN15 | 5103 | de | LND |  | 200 | 200 | N01C | N01C | 055 | 0 |  |
| EN21510305 |  | CA51 SR5103 - GA-Drwgs + Fdtn Loads |  | 120d | 2009-02-09 A | 2009-07-31 A | EE46510305, EJ46510305, ER165103, AD2230 FS+30d, EN155103 FF, EN21510205 SS | 100% |  | EN21510305 | EN21510305 | 87B | 51 |  | LND | E | N | EN21 | 5103 | de | LND |  | 200 |  | N01C | N01C |  |  |  |
| EN24510305 |  | CA51 SR5103 - Static Calc for Fdtn Loads |  | 33d | 2009-08-17 A | 2009-09-30 A | EN21510305 FS+10d | 100% |  | EN24510305 | EN24510305 | 87B | 51 |  | LND | E | N | EN24 | 5103 | de | LND |  | 200 |  | N01C | N01C |  |  |  |
| EN255103 |  | CA51 SR5103 - Loads for Civil | milestone | 0d | 2009-11-11 A | 2009-11-11 A | EN24510305 FF+31d | 100% |  | EN255103 | EN255103 | 87B | 51 | E | LND | E | N | EN25 | 5103 | de | LND |  | 200 | 200 | N01C | N01C | 055 | 0 |  |
| EN21510310 |  | CA51 SR5103 - GA-Drwgs + Final Loads |  | 81d | 2009-12-17 A | 2010-04-16 A | ER425103, EN21510305, EE46510308 FF, EN24510305, EJ46510308 FF, EN21510210 | 100% | TKB-S [320 h] | EN21510310 | EN21510310 | 87B | 51 |  | LEI | E | N | EN21 | 5103 | de | LND |  | 200 |  | N01C | N01C |  |  | 320,00 |
| EN24510310 |  | CA51 SR5103 - Final Static Calc |  | 100d | 2009-12-28 A | 2010-05-21 A | EN21510310, ER195103 FF | 100% | TKB-S [480 h] | EN24510310 | EN24510310 | 87B | 51 |  | LEI | E | N | EN24 | 5103 | de | LND |  | 200 |  | N01C | N01C |  |  | 480,00 |
| EN265103 |  | CA51 SR5103 - Layout dwgs input for KM dwgs |  | 35d | 2010-04-29 A | 2010-06-18 A | EN24510310 FF+9d, F4030 FF+20d | 100% | TKB-S [720 h] | EN265103 | EN265103 | 87B | 51 |  | LEI | E | N | EN26 | 5103 | st | LND |  | 200 |  | N01C | N01C |  |  | 720,00 |
| EN675103 |  | CA51 SR5103 - Grating Cut-Out drwgs |  | 70d | 2010-05-26 A | 2010-08-31 A | ER425103 FF, EN265103 FF+10d | 100% | TKB-S [160 h] | EN675103 | EN675103 | 87B | 51 | C | LEI | E | N | EN67 | 5103 | de | LND |  | 200 | 200 | N01C | N01C |  |  | 160,00 |
| EN27510305 |  | CA51 SR5103 - KM drwgs |  | 38d | 2010-07-07 A | 2010-08-27 A | P3N01D, EN265103, EN24510305 | 100% | KM Drwgs preparation by Cheljabinsk [170 t] | EN27510305 | EN27510305 | 87B | 51 |  | Chel | E | N | EN27 | 5103 | de | LND |  | 200 |  | N01C | N01C |  |  | 0,00 |
| EN645103 |  | CA51 SR5103 - Check Grating Cut-Out drwgs |  | 2d | 2010-08-23 A | 2010-08-24 A | EN675103 | 100% |  | EN645103 | EN645103 | 87B | 51 | C | LEI | E | N | EN67 | 5103 | de | LND |  | 200 | 200 | N01C | N01C |  |  |  |
| EN685103 |  | CA51 SR5103 - Grating Fabrication drwgs |  | 20d | 2010-08-25 A | 2010-09-21 A | EN675103, EN645103 | 100% |  | EN685103 | EN685103 | 87B | 51 | C | Chel | E | N | EN68 | 5103 | de | LND |  | 200 | 200 | N01C | N01C |  |  |  |
| EN27510310 |  | CA51 SR5103 - Check KM drwgs |  | 5d | 2010-08-30 A | 2010-09-03 A | EN27510305 | 100% |  | EN27510310 | EN27510310 | 87B | 51 |  | LEI | E | N | EN27 | 5103 | de | LND |  | 200 |  | N01C | N01C |  |  |  |
| EN285103 |  | CA51 SR5103 - Shop dwgs(KMD) by Vendor |  | 31d | 2010-09-06 A | 2010-10-18 A | EN27510310 | 100% |  | EN285103 | EN285103 | 87B | 51 |  | Chel | E | N | EN28 | 5103 | de | LND |  | 200 |  | N01C | N01C |  |  |  |

Notes:
- EC225103: P3 Activity Log Info: TKB-B Keyplan to Subcontractor
- EC45510315: P3 Activity Log Info: incl. PMT approval
- EC45510310: P3 Activity Log Info: incl. PMT approval

| ID | WBS | Activity | Type | Duration | Start | Finish | Predecessors | Complete | Planned start | Planned finish | UDF_SAVE ACTID | UDF_SAVE ACT ID | Department | Constr. Area | PMT-Area | PMT-Respons. | WBS Phase | WBS Discipline | WBS Type of Work | WBS Objects | IMS | UPT | PMT-Schedule Org | PMT-Phase | Pro Unit/DocCode |
| --- | --- | --- | --- | --- | --- | --- | --- | --- | --- | --- | --- | --- | --- | --- | --- | --- | --- | --- | --- | --- | --- | --- | --- | --- | --- |
|  | R | **R Piping** |  |  | 2008-04-01 | 2011-03-28 |  |  |  |  |  |  |  |  |  |  |  |  |  |  |  |  |  |  |  |
| ER155103 |  | CA51 SR5103 - Conceptual Piping |  | 169d | 2008-04-01 A | 2008-11-28 A | ER155102 FF | 100% |  |  | ER155103 | ER155103 | 876 | 51 | 200 | LND | E | R | ER15 | 5103 | PL | LND |  |  |  |
| ER305103 |  | CA51 SR5103 - CAD Model Piping / Equipment |  | 531d | 2008-05-02 A | 2010-06-16 A | ER155103 SS, ER365103 FF+10d | 100% |  |  | ER305103 | ER305103 | 876 | 51 | 200 | LNI | E | R | ER30 | 5103 | PL | LND |  |  |  |
| ER165103 |  | CA51 SR5103 - prelim Loads for Struc Steel |  | 20d | 2009-01-05 A | 2009-01-30 A | ER155103 FF | 100% |  |  | ER165103 | ER165103 | 876 | 51 | 200 | LND | E | R | ER16 | 5103 | PL | LND |  |  |  |
| ER425103 |  | CA51 SR5103 - Stress Calculation / Final Loads |  | 98d | 2009-11-16 A | 2010-04-09 A | F4030 FF | 100% |  |  | ER425103 | ER425103 | 872 | 51 | 200 | LND | E | R | ER42 | 5103 | PL | LND |  |  |  |
| ER195103 |  | CA51 SR5103 - Final Loads for Struc Steel | milestone | 0d | 2010-01-04 A | 2010-01-04 A | ER165103 FF, F4030 FF+5d, EN21510310 SF-5d | 100% |  |  | ER195103 | ER195103 | 876 | 51 | 200 | LNI | E | R | ER19 | 5103 | PL | LND |  |  |  |
| ER455103 |  | CA51 SR5103 - Piping Isometrics |  | 104d | 2010-06-28 A | 2010-11-19 A | ER425103, ER395101 FF+20d, ER305103 FF | 100% |  |  | ER455103 | ER455103 | 876 | 51 | 200 | LEI | E | R | ER45 | 5103 | 5 | LND |  |  |  |
| ER495103 |  | CA51 SR5103 - Design Check / Release Isos & BOM |  | 173d | 2010-07-26 A | 2011-03-28 A | ER455103 FF | 100% |  |  | ER495103 | ER495103 | 876 | 51 | 200 | LEI | E | R | ER49 | 5103 | 5 | LND |  |  |  |
| ER475103 |  | CA51 SR5103 - Piping Layout drwgs |  | 69d | 2010-09-17 A | 2010-12-23 A | ER475101 FF, ER395101 FF+20d, ER305103 | 100% |  |  | ER475103 | ER475103 | 876 | 51 | 200 | LEI | E | R | ER47 | 5103 | 5 | LND |  |  |  |
| ER445103 |  | CA51 SR5103 - Piping Isometrics (UG) |  | 25d | 2010-10-04 A | 2010-11-05 A | ER440000 FF, EC305103 SS+20d | 100% |  |  | ER445103 | ER445103 | 876 | 51 | 200 | LND | E | R | ER44 | 5103 | 4 | LND | 200 | E |  |
|  | E | **E Electrical** |  |  | 2008-10-06 | 2010-08-13 |  |  |  |  |  |  |  |  |  |  |  |  |  |  |  |  |  |  |  |
| EE46510305 |  | CA51 SR5103 - prelim Loads for Struc Steel |  | 10d | 2008-10-06 A | 2008-10-17 A | F3060 FF | 100% |  |  | EE46510305 | EE46510305 | 874 | 51 |  | LND | E | E | EE11 | 5103 | E | LND |  | E |  |
| EE905103 |  | CA51 SR5103 - Earthing Details |  | 30d | 2009-05-07 A | 2009-06-19 A | EE901201 SS | 100% |  |  | EE905103 | EE905103 | 874 | 51 |  | LND | E | E | EE90 | 5103 | E | LND |  | E |  |
| EE565103 |  | CA51 SR5103 - Cable Pulling Details |  | 164d | 2009-12-03 A | 2010-07-30 A | EE46510310 FF, EE500130 | 100% |  |  | EE565103 | EE565103 | 874 | 51 |  | LEI | E | E | EE56 | 5103 | E | LND |  | E |  |
| EE46510310 |  | CA51 SR5103 - El. CableTray Layout Pl. 1st Issue |  | 172d | 2009-12-07 A | 2010-08-13 A | EE460000, F4030 FF+70d | 100% |  |  | EE46510310 | EE46510310 | 874 | 51 |  | LEI | E | E | EE46 | 5103 | E | LND |  | E |  |
| EE46510308 |  | CA51 SR5103 - Final Loads for Struc Steel |  | 41d | 2009-12-14 A | 2010-02-12 A | EE46510305 | 100% |  |  | EE46510308 | EE46510308 | 874 | 51 |  | LEI | E | E | EE12 | 5103 | E | LND |  | E |  |
| EE765103 |  | CA51 SR5103 - Layout Plan Light.& Sockets 1st Issue |  | 140d | 2010-01-26 A | 2010-08-13 A | EE000180 FS+10d | 100% |  |  | EE765103 | EE765103 | 874 | 51 |  | LEI | E | E | EE76 | 5103 | E | LND |  | E |  |
|  | J | **J Instrumentation** |  |  | 2008-10-06 | 2010-08-13 |  |  |  |  |  |  |  |  |  |  |  |  |  |  |  |  |  |  |  |
| EJ46510305 |  | CA51 SR5103 - prelim Loads for Struc Steel |  | 15d | 2008-10-06 A | 2008-10-24 A | F3060 FF | 100% |  |  | EJ46510305 | EJ46510305 | 86E | 51 |  | LND | E | J | EJ11 | 5103 | I | LND |  | E | 999 |
| EJ46510308 |  | CA51 SR5103 - Final Loads for Struc Steel |  | 10d | 2010-02-22 A | 2010-03-05 A | EJ46510305 | 100% |  |  | EJ46510308 | EJ46510308 | 86E | 51 |  | LEI | E | J | EJ12 | 5103 | I | LND |  | E | 999 |
| EJ46510310 |  | CA51 SR5103 - Instr Cable Tray Layout Plans 1st Issue |  | 116d | 2010-03-01 A | 2010-08-13 A | EE46510310 FF, F4030 FF, F4460 | 100% |  |  | EJ46510310 | EJ46510310 | 86E | 51 |  | LEI | E | J | EJ41 | 5103 | I | LND |  | E | 999 |
|  | 5104 | **5104 Pipe Rack 1 - Part 4 - CA51** |  |  | 2008-03-03 | 2011-03-28 |  |  |  |  |  |  |  |  |  |  |  |  |  |  |  |  |  |  |  |
|  | C | **C Civil** |  |  | 2009-12-15 | 2010-09-21 |  |  |  |  |  |  |  |  |  |  |  |  |  |  |  |  |  |  |  |
| EC225104 |  | CA51 SR5104 - Layout Drwg / Loads IFD |  | 10d | 2009-12-15 A | 2009-12-30 A | EC225101 FF, EN255104 FF | 100% |  |  | EC225104 | EC225104 | 87A | 51 | 200 | LND | E | C | EC22 | 5104 | de | LND | 200 | E |  |
| EC265104 |  | CA51 SR5104 - Civil Static Calc Fdtn |  | 173d | 2010-01-18 A | 2010-09-21 A | EC225104, P3C0BD FS+10d, EC265103 SS+5d | 100% |  |  | EC265104 | EC265104 | 87A | 51 | 200 | IPR | E | C | EC26 | 5104 | de | LND | 200 | E | 5104C14 |
| EC155104 |  | CA51 SR5104 - Piling drwgs AFC |  | 32d | 2010-01-25 A | 2010-03-09 A | EC265104 SS+5d | 100% |  |  | EC155104 | EC155104 | 87A | 51 | 200 | IPR | E | C | EC15 | 5104 | PI | LND |  |  | 5104C16 |
| EC285104 |  | CA51 SR5104 - Formw/Reinforce drwgs Found. AFC |  | 56d | 2010-02-15 A | 2010-05-05 A | EC265104 SS+15d, EC155104 SS+10d, EC28510405 SS | 100% |  |  | EC285104 | EC285104 | 87A | 51 | 200 | IPR | E | C | EC28 | 5104 | cq | LND | 200 | E | 5104C21 |
| EC28510405 |  | CA51 SR5104 - Precast Layout drwgs AFC |  | 106d | 2010-02-15 A | 2010-07-16 A | EC155104 SS+15d | 100% |  |  | EC28510405 | EC28510405 | 87A | 51 | 200 | IPR | E | C | EC28 | 5104 | PRE | LND | 200 | E | 5104C31 |
| EC28510406 |  | CA51 SR5104 - Precast Formw/Reinf. drwgs AFC |  | 101d | 2010-02-22 A | 2010-07-16 A | EC28510405 FF | 100% |  |  | EC28510406 | EC28510406 | 87A | 51 | 200 | IPR | E | C | EC28 | 5104 | PRE | LND | 200 | E | 5104C53 |
| EC45510410 |  | CA51 SR5104 - Civil Layout drwgs IFC | milestone | 0d | 2010-03-30 A | 2010-03-30 A | EC285104 FS-30d | 100% |  |  | EC45510410 | EC45510410 | 87A | 51 | 200 | IPR | E | C | EC45 | 5104 | ar | LND |  | E |  |
| EC45510415 |  | CA51 SR5104 - Review Civil Layout drwgs |  | 19d | 2010-04-05 A | 2010-04-30 A | EC45510410 | 100% | 2010-04-06 | 2010-04-30 | EC45510415 | EC45510415 | 87A | 51 | 200 | LND | E | C | EC45 | 5104 | ar | LND |  | E |  |

Notes:
- EC225104: P3 Activity Log Info: TKB-B Keyplan to Subcontractor
- EC45510410: P3 Activity Log Info: incl. PMT approval
- EC45510415: P3 Activity Log Info: incl. PMT approval

| ID | WBS | Activity | Type | Duration | Start | Finish | Predecessors | Complete | Resources | UDF_SAVE ACTID | UDF_SAVE ACT ID | Department | Type of Work | Constr. Area | Inquiry/Order No | PMT-Area | PMT-Schedule Org | PMT-Discipline | PMT-Phase | PMT-Respons. | Zeigen/n. Zeigen | WBS Phase | WBS Discipline | WBS Type of Work | WBS Objects | IMS | UPT | TB26 Ressource Budget |
| --- | --- | --- | --- | --- | --- | --- | --- | --- | --- | --- | --- | --- | --- | --- | --- | --- | --- | --- | --- | --- | --- | --- | --- | --- | --- | --- | --- | --- |
|  | N | **N Structural Steel** |  |  | 2008-03-03 | 2010-10-18 |  |  |  |  |  |  |  |  |  |  |  |  |  |  |  |  |  |  |  |  |  |  |
| EN155104 |  | CA51 SR5104 - CAD Model/Concepts StrSteel |  | 126d | 2008-03-03 A | 2008-08-29 A | EN155103 FF | 100% |  | EN155104 | EN155104 | 87B | N01D | 51 | N01D | 200 | 200 | 055 | E | LND | 0 | E | N | EN15 | 5104 | de | LND |  |
| EN21510405 |  | CA51 SR5104 - GA-Drwgs + Fdtn Loads |  | 120d | 2009-02-09 A | 2009-07-31 A | EJ46510405, EN155104 FF, AD2230 FF+30d, ER165104, EN21510305 SS, EE46510405 | 100% |  | EN21510405 | EN21510405 | 87B | N01D | 51 | N01D | 200 |  |  |  | LND |  | E | N | EN21 | 5104 | de | LND |  |
| EN24510405 |  | CA51 SR5104 - Static Calc for Fdtn Loads |  | 33d | 2009-08-17 A | 2009-09-30 A | EN21510405 FS+10d | 100% |  | EN24510405 | EN24510405 | 87B | N01D | 51 | N01D | 200 |  |  |  | LND |  | E | N | EN24 | 5104 | de | LND |  |
| EN255104 |  | CA51 SR5104 - Loads for Civil | milestone | 0d | 2009-11-11 A | 2009-11-11 A | EN24510405 FF+31d | 100% |  | EN255104 | EN255104 | 87B | N01D | 51 | N01D | 200 | 200 | 055 | E | LND | 0 | E | N | EN25 | 5104 | de | LND |  |
| EN21510410 |  | CA51 SR5104 - GA-Drwgs + Final Loads |  | 83d | 2009-12-17 A | 2010-04-20 A | EN21510310 FF, ER425104, EJ46510408 FF, EN24510405, EN21510405, EE46510408 FF | 100% | TKB-S [240 h] | EN21510410 | EN21510410 | 87B | N01D | 51 | N01D | 200 |  |  |  | LEI |  | E | N | EN21 | 5104 | de | LND | 240,00 |
| EN24510410 |  | CA51 SR5104 - Final Static Calc |  | 111d | 2009-12-28 A | 2010-06-08 A | EN21510410, ER195104 FF | 100% | TKB-S [480 h] | EN24510410 | EN24510410 | 87B | N01D | 51 | N01D | 200 |  |  |  | LEI |  | E | N | EN24 | 5104 | de | LND | 480,00 |
| EN265104 |  | CA51 SR5104 - Layout dwgs input for KM dwgs |  | 42d | 2010-04-20 A | 2010-06-18 A | F4030 FF+20d, EN24510410 FF+8d | 100% | TKB-S [720 h] | EN265104 | EN265104 | 87B | N01D | 51 | N01D | 200 |  |  |  | LEI |  | E | N | EN26 | 5104 | st | LND | 720,00 |
| EN675104 |  | CA51 SR5104 - Grating Cut-Out drwgs |  | 68d | 2010-05-28 A | 2010-08-31 A | ER425104 FF | 100% | TKB-S [160 h] | EN675104 | EN675104 | 87B | N01D | 51 | N01D | 200 | 200 |  | C | LEI |  | E | N | EN67 | 5104 | de | LND | 160,00 |
| EN27510405 |  | CA51 SR5104 - KM drwgs |  | 38d | 2010-07-07 A | 2010-08-27 A | P3N01D, EN24510405, EN265104, E3C170 FF | 100% | KM Drwgs preparation by Cheljabinsk [110 t] | EN27510405 | EN27510405 | 87B | N01D | 51 | N01D | 200 |  |  |  | Chel |  | E | N | EN27 | 5104 | de | LND | 0,00 |
| EN645104 |  | CA51 SR5104 - Check Grating Cut-Out drwgs |  | 2d | 2010-08-23 A | 2010-08-24 A | EN675104 | 100% |  | EN645104 | EN645104 | 87B | N01D | 51 | N01D | 200 | 200 |  | C | LEI |  | E | N | EN67 | 5104 | de | LND |  |
| EN685104 |  | CA51 SR5104 - Grating Fabrication drwgs |  | 20d | 2010-08-25 A | 2010-09-21 A | EN675104, EN645104 | 100% |  | EN685104 | EN685104 | 87B | N01D | 51 | N01D | 200 | 200 |  | C | Chel |  | E | N | EN68 | 5104 | de | LND |  |
| EN27510410 |  | CA51 SR5104 - Check KM drwgs |  | 5d | 2010-08-30 A | 2010-09-03 A | EN27510405 | 100% |  | EN27510410 | EN27510410 | 87B | N01D | 51 | N01D | 200 |  |  |  | LEI |  | E | N | EN27 | 5104 | de | LND |  |
| EN285104 |  | CA51 SR5104 - Shop dwgs(KMD) by Vendor |  | 31d | 2010-09-06 A | 2010-10-18 A | EN27510410 | 100% |  | EN285104 | EN285104 | 87B | N01D | 51 | N01D | 200 |  |  |  | Chel |  | E | N | EN28 | 5104 | de | LND |  |
|  | R | **R Piping** |  |  | 2008-04-01 | 2011-03-28 |  |  |  |  |  |  |  |  |  |  |  |  |  |  |  |  |  |  |  |  |  |  |
| ER155104 |  | CA51 SR5104 - Conceptual Piping |  | 169d | 2008-04-01 A | 2008-11-28 A | ER155103 FF+10d | 100% |  | ER155104 | ER155104 | 876 |  | 51 |  | 200 |  |  |  | LND |  | E | R | ER15 | 5104 | PL | LND |  |
| ER305104 |  | CA51 SR5104 - CAD Model Piping / Equipment |  | 531d | 2008-05-02 A | 2010-06-16 A | ER155104 SS, ER365104 FF+10d | 100% |  | ER305104 | ER305104 | 876 |  | 51 |  | 200 |  |  |  | LNI |  | E | R | ER30 | 5104 | PL | LND |  |
| ER165104 |  | CA51 SR5104 - prelim Loads for Struc Steel |  | 20d | 2009-01-05 A | 2009-01-30 A | ER155104 FF | 100% |  | ER165104 | ER165104 | 876 |  | 51 |  | 200 |  |  |  | LND |  | E | R | ER16 | 5104 | PL | LND |  |
| ER365104 |  | CA51 SR5104 - CAD Model Review 60% |  | 12d | 2009-11-02 A | 2009-11-17 A | F4030 SS | 100% |  | ER365104 | ER365104 | 876 |  | 51 |  | 200 |  |  |  | LND |  | E | R | ER36 | 5104 | 2 | LND |  |
| ER425104 |  | CA51 SR5104 - Stress Calculation / Final Loads |  | 98d | 2009-11-16 A | 2010-04-09 A | F4030 FF | 100% |  | ER425104 | ER425104 | 872 |  | 51 |  | 200 |  |  |  | LND |  | E | R | ER42 | 5104 | PL | LND |  |
| ER195104 |  | CA51 SR5104 - Final Loads for Struc Steel | milestone | 0d | 2010-01-04 A | 2010-01-04 A | F4030 FF+5d, EN21510410 SF-5d, ER165104 FF | 100% |  | ER195104 | ER195104 | 876 |  | 51 |  | 200 |  |  |  | LNI |  | E | R | ER19 | 5104 | PL | LND |  |
| ER455104 |  | CA51 SR5104 - Piping Isometrics |  | 104d | 2010-06-28 A | 2010-11-19 A | ER395101 FF+20d, ER305104 FF+5d, ER425104 | 100% |  | ER455104 | ER455104 | 876 |  | 51 |  | 200 |  |  |  | LEI |  | E | R | ER45 | 5104 | 5 | LND |  |
| ER495104 |  | CA51 SR5104 - Design Check / Release Isos & BOM |  | 173d | 2010-07-26 A | 2011-03-28 A | ER455104 FF | 100% |  | ER495104 | ER495104 | 876 |  | 51 |  | 200 |  |  |  | LEI |  | E | R | ER49 | 5104 | 5 | LND |  |
| ER475104 |  | CA51 SR5104 - Piping Layout drwgs |  | 69d | 2010-09-17 A | 2010-12-23 A | ER395101 FF+20d, ER305104, ER475101 FF | 100% |  | ER475104 | ER475104 | 876 |  | 51 |  | 200 |  |  |  | LEI |  | E | R | ER47 | 5104 | 5 | LND |  |
| ER445104 |  | CA51 SR5104 - Piping Isometrics (UG) |  | 25d | 2010-10-04 A | 2010-11-05 A | ER440000 FF, EC305104 SS+20d | 100% |  | ER445104 | ER445104 | 876 |  | 51 |  | 200 | 200 |  | E | LND |  | E | R | ER44 | 5104 | 4 | LND |  |

| ID | WBS | Activity | Type | Duration | Start | Finish | Predecessors | Complete | Resources | UDF_SAVE ACTID | UDF_SAVE ACT ID | Department | Constr. Area | PMT-Phase | PMT-Respons. | WBS Phase | WBS Discipline | WBS Type of Work | WBS Objects | IMS | UPT | Pro Unit/DocCode | UDF_CONTRACT INDICATOR | PMT-Area | PMT-Schedule Org | TB26 Ressource Budget | Inquiry/Order No | Zeigen/n. Zeigen | Type of Work | PMT-Discipline |
| --- | --- | --- | --- | --- | --- | --- | --- | --- | --- | --- | --- | --- | --- | --- | --- | --- | --- | --- | --- | --- | --- | --- | --- | --- | --- | --- | --- | --- | --- | --- |
|  | E | **E Electrical** |  |  | 2008-10-06 | 2010-08-13 |  |  |  |  |  |  |  |  |  |  |  |  |  |  |  |  |  |  |  |  |  |  |  |  |
| EE46510405 |  | CA51 SR5104 - prelim Loads for Struc Steel |  | 10d | 2008-10-06 A | 2008-10-17 A | F3060 FF | 100% |  | EE46510405 | EE46510405 | 874 | 51 | E | LND | E | E | EE11 | 5104 | E | LND |  |  |  |  |  |  |  |  |  |
| EE905104 |  | CA51 SR5104 - Earthing Details |  | 30d | 2009-05-07 A | 2009-06-19 A | EE901201 SS | 100% |  | EE905104 | EE905104 | 874 | 51 | E | LND | E | E | EE90 | 5104 | E | LND |  |  |  |  |  |  |  |  |  |
| EE565104 |  | CA51 SR5104 - Cable Pulling Details |  | 164d | 2009-12-03 A | 2010-07-30 A | EE46510410 FF, EE500130 | 100% |  | EE565104 | EE565104 | 874 | 51 | E | LEI | E | E | EE56 | 5104 | E | LND |  |  |  |  |  |  |  |  |  |
| EE46510410 |  | CA51 SR5104 - El. CableTray Layout Pl. 1st Issue |  | 172d | 2009-12-07 A | 2010-08-13 A | F4030 FF+70d, EE460000 | 100% |  | EE46510410 | EE46510410 | 874 | 51 | E | LEI | E | E | EE46 | 5104 | E | LND |  |  |  |  |  |  |  |  |  |
| EE46510408 |  | CA51 SR5104 - Final Loads for Struc Steel |  | 41d | 2009-12-21 A | 2010-02-19 A | EE46510405 | 100% |  | EE46510408 | EE46510408 | 874 | 51 | E | LEI | E | E | EE12 | 5104 | E | LND |  |  |  |  |  |  |  |  |  |
| EE765104 |  | CA51 SR5104 - Layout Plan Light.& Sockets 1st Issue |  | 140d | 2010-01-26 A | 2010-08-13 A | EE000180 FS+10d | 100% |  | EE765104 | EE765104 | 874 | 51 | E | LEI | E | E | EE76 | 5104 | E | LND |  |  |  |  |  |  |  |  |  |
|  | J | **J Instrumentation** |  |  | 2008-10-06 | 2010-08-13 |  |  |  |  |  |  |  |  |  |  |  |  |  |  |  |  |  |  |  |  |  |  |  |  |
| EJ46510405 |  | CA51 SR5104 - prelim Loads for Struc Steel |  | 15d | 2008-10-06 A | 2008-10-24 A | F3060 FF | 100% |  | EJ46510405 | EJ46510405 | 86E | 51 | E | LND | E | J | EJ11 | 5104 | I | LND | 999 |  |  |  |  |  |  |  |  |
| EJ46510408 |  | CA51 SR5104 - Final Loads for Struc Steel |  | 10d | 2010-02-22 A | 2010-03-05 A | EJ46510405 | 100% |  | EJ46510408 | EJ46510408 | 86E | 51 | E | LEI | E | J | EJ12 | 5104 | I | LND | 999 |  |  |  |  |  |  |  |  |
| EJ46510410 |  | CA51 SR5104 - Instr Cable Tray Layout Plans 1st Issue |  | 116d | 2010-03-01 A | 2010-08-13 A | F4030 FF, F4460, EE46510410 FF | 100% |  | EJ46510410 | EJ46510410 | 86E | 51 | E | LEI | E | J | EJ41 | 5104 | I | LND | 999 |  |  |  |  |  |  |  |  |
|  | 52 | **52 CA52 - Piperack (between CA11/51)** |  |  | 2008-03-03 | 2011-02-18 |  |  |  |  |  |  |  |  |  |  |  |  |  |  |  |  |  |  |  |  |  |  |  |  |
|  | 5201 | **5201 Pipe Rack 2 - CA52** |  |  | 2008-03-03 | 2011-02-18 |  |  |  |  |  |  |  |  |  |  |  |  |  |  |  |  |  |  |  |  |  |  |  |  |
|  | C | **C Civil** |  |  | 2010-03-01 | 2010-12-01 |  |  |  |  |  |  |  |  |  |  |  |  |  |  |  |  |  |  |  |  |  |  |  |  |
| EC225201 |  | CA52 SR5201 - Layout Drwg / Loads IFD |  | 10d | 2010-03-01 A | 2010-03-12 A | EN255201 | 100% |  | EC225201 | EC225201 | 87A | 52 | E | LND | E | C | EC22 | 5201 | de | LND | 5200C01 | UDF_G3 | 200 | 200 |  |  |  |  |  |
| EC155201 |  | CA52 SR5201 - Piling drwgs AFC |  | 68d | 2010-03-15 A | 2010-06-22 A | EC265201 SS, HEC15 FF, EC151110 SS | 100% |  | EC155201 | EC155201 | 87A | 52 |  | IPR | E | C | EC15 | 5201 | PI | LND | 5201C16 | UDF_G3 | 200 |  |  |  |  |  |  |
| EC265201 |  | CA52 SR5201 - Civil Static Calc Fdtn |  | 155d | 2010-03-15 A | 2010-10-21 A | F4040 FS-5d, EC225201, P3C0BD FS+10d | 100% |  | EC265201 | EC265201 | 87A | 52 | E | IPR | E | C | EC26 | 5201 | de | LND | 5201C14 | UDF_G3 | 200 | 200 |  |  |  |  |  |
| EC285201 |  | CA52 SR5201 - Formw/Reinforce drwgs Found. AFC |  | 144d | 2010-03-30 A | 2010-10-21 A | EC155201 SS+11d, IMS-E-000150 FF, EC265201 SS+10d | 100% |  | EC285201 | EC285201 | 87A | 52 | E | IPR | E | C | EC28 | 5201 | cq | LND | 5201C21 | UDF_G3 | 200 | 200 |  |  |  |  |  |
| EC28520105 |  | CA52 SR5201 - Precast Layout drwgs AFC |  | 144d | 2010-03-30 A | 2010-10-21 A | EC155201 SS+15d | 100% |  | EC28520105 | EC28520105 | 87A | 52 | E | IPR | E | C | EC28 | 5201 | PRE | LND | 5201C31 | UDF_G3 | 200 | 200 |  |  |  |  |  |
| EC28520106 |  | CA52 SR5201 - Precast Formw/Reinf. drwgs AFC |  | 144d | 2010-03-30 A | 2010-10-21 A | EC28520105 FF, IMS-E-000140 FF | 100% |  | EC28520106 | EC28520106 | 87A | 52 | E | IPR | E | C | EC28 | 5201 | PRE | LND | 5201C53 | UDF_G3 | 200 | 200 |  |  |  |  |  |
| EC075201 |  | CA52 SR5201 - Issue of working drwgs (AFC) by RDI |  | 157.75d | 2010-04-21 A | 2010-12-01 A | EC155201 SS+25d, EC28520105 FF | 100% | TKB-B [1520 h] | EC075201 | EC075201 | 87A | 52 | E | IPR | E | C | EC07 | 5201 | cq | LND | 1010C13 | UDF_G3 | 200 |  | 1520,00 | 999 | FL |  |  |
| EC075200 |  | CA52 SR5201 - Check & Release of working drwgs (AFC) |  | 131d | 2010-04-28 A | 2010-10-29 A | EC075201 SS+5d | 100% | TKB-B [208 h] | EC075200 | EC075200 | 87A | 52 | E | LND | E | C | EC07 | 5201 | cq | LND |  | UDF_G3 | 200 |  | 208,00 | 999 | FL |  |  |
|  | N | **N Structural Steel** |  |  | 2008-03-03 | 2011-02-18 |  |  |  |  |  |  |  |  |  |  |  |  |  |  |  |  |  |  |  |  |  |  |  |  |
| EN155201 |  | CA52 SR5201 - CAD Model/Concepts StrSteel |  | 126d | 2008-03-03 A | 2008-08-29 A | EN155101 FF | 100% |  | EN155201 | EN155201 | 87B | 52 | E | LND | E | N | EN15 | 5201 | de | LND |  |  | 200 | 200 |  | N01E | 0 | N01E | 055 |
| EN21520105 |  | CA52 SR5201 - GA-Drwgs + Fdtn Loads |  | 128d | 2009-11-23 A | 2010-05-31 A | EE46520105, EJ46520105, AD2230 FS+35d, EN155201 FF, ER165201 | 100% | TKB-S [320 h] | EN21520105 | EN21520105 | 87B | 52 |  | LEI | E | N | EN21 | 5201 | de | LND |  |  | 200 |  | 320,00 | N01E |  | N01E |  |
| EN24520105 |  | CA52 SR5201 - Static Calc for Fdtn Loads |  | 16d | 2009-12-21 A | 2010-01-15 A | EN21520105 SS | 100% | TKB-S [320 h] | EN24520105 | EN24520105 | 87B | 52 |  | LND | E | N | EN24 | 5201 | de | LND |  |  | 200 |  | 320,00 | N01E |  | N01E |  |
| EN255201 |  | CA52 SR5201 - Loads for Civil | milestone | 0d | 2010-01-15 A | 2010-01-15 A | EN24520105 FF | 100% |  | EN255201 | EN255201 | 87B | 52 | E | LND | E | N | EN25 | 5201 | de | LND |  |  | 200 | 200 |  | N01E | 0 | N01E | 055 |
| EN21520110 |  | CA52 SR5201 - GA-Drwgs + Final Loads |  | 171d | 2010-01-18 A | 2010-09-17 A | E3U1250 FF+10d, ER425201 FF+10d, EN21520105 FS+10d, EJ46520108 FF+10d, EN24520105, EE46520108 FF+10d | 100% |  | EN21520110 | EN21520110 | 87B | 52 |  | LEI | E | N | EN21 | 5201 | de | LND |  |  | 200 |  |  | N01E |  | N01E |  |
| EN24520110 |  | CA52 SR5201 - Final Static Calc |  | 171d | 2010-03-08 A | 2010-11-05 A | ER195201 FF, EN21520110 FF+10d | 100% | TKB-S [480 h] | EN24520110 | EN24520110 | 87B | 52 |  | LEI | E | N | EN24 | 5201 | de | LND |  |  | 200 |  | 480,00 | N01E |  | N01E |  |
| EN265201 |  | CA52 SR5201 - Layout dwgs input for KM dwgs |  | 55d | 2010-08-23 A | 2010-11-05 A | F4040 FF+15d, EN24520110 FF | 100% | TKB-S [960 h] | EN265201 | EN265201 | 87B | 52 |  | LEI | E | N | EN26 | 5201 | st | LND |  |  | 200 |  | 960,00 | N01E |  | N01E |  |
| EN27520105 |  | CA52 SR5201 - KM drwgs |  | 42.38d | 2010-10-27 A | 2010-12-28 A | EN265201, EN24520105 | 100% | KM Drwgs preparation by Cheljabinsk [130 t] | EN27520105 | EN27520105 | 87B | 52 |  | Chel | E | N | EN27 | 5201 | de | LND |  |  | 200 |  | 0,00 | N01E |  | N01E |  |
| EN675201 |  | CA52 SR5201 - Grating Cut-Out drwgs |  | 37d | 2010-11-15 A | 2011-01-07 A | ER425201 FF, F4460 FF+10d, EN27520110 | 100% | TKB-S [240 h] | EN675201 | EN675201 | 87B | 52 | C | LEI | E | N | EN67 | 5201 | de | LND |  |  | 200 | 200 | 240,00 | N01E |  | N01E |  |
| EN27520110 |  | CA52 SR5201 - Check KM drwgs |  | 7d | 2010-12-29 A | 2011-01-07 A | EN27520105 | 100% |  | EN27520110 | EN27520110 | 87B | 52 |  | LEI | E | N | EN27 | 5201 | de | LND |  |  | 200 |  |  | N01E |  | N01E |  |
| EN285201 |  | CA52 SR5201 - Shop dwgs(KMD) by Vendor |  | 37d | 2010-12-29 A | 2011-02-18 A | EN27520110 FF+13d | 100% |  | EN285201 | EN285201 | 87B | 52 |  | Chel | E | N | EN28 | 5201 | de | LND |  |  | 200 |  |  | N01E |  | N01E |  |
| EN645201 |  | CA52 SR5201 - Check Grating Cut-Out drwgs |  | 27d | 2011-01-10 A | 2011-02-15 A | EN675201 | 100% |  | EN645201 | EN645201 | 87B | 52 | C | LEI | E | N | EN67 | 5201 | de | LND |  |  | 200 | 200 |  | N01E |  | N01E |  |
| EN685201 |  | CA52 SR5201 - Grating Fabrication drwgs |  | 21d | 2011-01-17 A | 2011-02-14 A | EN675201, EN645201 FF-7d | 100% |  | EN685201 | EN685201 | 87B | 52 | C | Chel | E | N | EN68 | 5201 | de | LND |  |  | 200 | 200 |  | N01E |  | N01E |  |

Notes:
- EC225201: P3 Activity Log Info: TKB-B Keyplan to Subcontractor

| ID | WBS | Activity | Type | Duration | Start | Finish | Predecessors | Complete | Constraint | Resources | UDF_SAVE ACTID | UDF_SAVE ACT ID | Department | Constr. Area | PMT-Area | PMT-Respons. | WBS Phase | WBS Discipline | WBS Type of Work | WBS Objects | IMS | UPT | PMT-Schedule Org | PMT-Phase | Pro Unit/DocCode | Zeigen/n. Zeigen | TB26 Ressource Budget | Inquiry/Order No |
| --- | --- | --- | --- | --- | --- | --- | --- | --- | --- | --- | --- | --- | --- | --- | --- | --- | --- | --- | --- | --- | --- | --- | --- | --- | --- | --- | --- | --- |
|  | R | **R Piping** |  |  | 2008-04-01 | 2011-01-21 |  |  |  |  |  |  |  |  |  |  |  |  |  |  |  |  |  |  |  |  |  |  |
| ER155201 |  | CA52 SR5201 - Conceptual Piping |  | 169d | 2008-04-01 A | 2008-11-28 A | ER155101 FF+10d | 100% |  |  | ER155201 | ER155201 | 876 | 52 | 200 | LND | E | R | ER15 | 5201 | PL | LND |  |  |  |  |  |  |
| ER305201 |  | CA52 SR5201 - CAD Model Piping / Equipment |  | 538d | 2008-06-02 A | 2010-07-23 A | ER395201 FF+10d, ER155201 SS, ER365201 FF+20d | 100% |  |  | ER305201 | ER305201 | 876 | 52 | 200 | LNI | E | R | ER30 | 5201 | PL | LND |  |  |  |  |  |  |
| ER165201 |  | CA52 SR5201 - prelim Loads for Struc Steel |  | 20d | 2009-01-05 A | 2009-01-30 A | ER155201 FF | 100% |  |  | ER165201 | ER165201 | 876 | 52 | 200 | LND | E | R | ER16 | 5201 | PL | LND |  |  |  |  |  |  |
| ER425201 |  | CA52 SR5201 - Stress Calculation / Final Loads |  | 79d | 2009-12-14 A | 2010-04-09 A | F4040 FF | 100% |  |  | ER425201 | ER425201 | 872 | 52 | 200 | LND | E | R | ER42 | 5201 | PL | LND |  |  |  |  |  |  |
| ER365201 |  | CA52 SR5201 - CAD Model Review 60% |  | 15d | 2010-03-01 A | 2010-03-19 A | F4040 FF | 100% |  |  | ER365201 | ER365201 | 876 | 52 | 200 | LND | E | R | ER36 | 5201 | 2 | LND |  |  |  |  |  |  |
| ER195201 |  | CA52 SR5201 - Final Loads for Struc Steel | milestone | 0d | 2010-04-13 A | 2010-04-13 A | EN21520110 SF-10d, ER165201 FF, F4040 FF+15d | 100% |  |  | ER195201 | ER195201 | 876 | 52 | 200 | LNI | E | R | ER19 | 5201 | PL | LND |  |  |  |  |  |  |
| ER395201 |  | CA52 SR5201 - CAD Model Review 90% |  | 10d | 2010-06-28 A | 2010-07-09 A | F4460 FF | 100% |  |  | ER395201 | ER395201 | 876 | 52 | 200 | LND | E | R | ER39 | 5201 | 3 | LND |  |  |  |  |  |  |
| ER475201 |  | CA52 SR5201 - Piping Layout drwgs |  | 87d | 2010-09-17 A | 2011-01-20 A | ER395201 FF+20d, ER475101 FF+18d, ER305201 | 100% |  |  | ER475201 | ER475201 | 876 | 52 | 200 | LEI | E | R | ER47 | 5201 | 5 | LND |  |  |  |  |  |  |
| ER455201 |  | CA52 SR5201 - Piping Isometrics |  | 59d | 2010-09-27 A | 2010-12-17 A | ER305201 FF+15d, ER395201 FS+10d, ER425201 | 100% |  |  | ER455201 | ER455201 | 876 | 52 | 200 | LEI | E | R | ER45 | 5201 | 5 | LND |  |  |  |  |  |  |
| ER495201 |  | CA52 SR5201 - Design Check / Release Isos & BOM |  | 82d | 2010-09-27 A | 2011-01-21 A | ER455201 FF | 100% |  |  | ER495201 | ER495201 | 876 | 52 | 200 | LEI | E | R | ER49 | 5201 | 5 | LND |  |  |  |  |  |  |
| ER445201 |  | CA52 SR5201 - Piping Isometrics (UG) |  | 25d | 2010-10-04 A | 2010-11-05 A | ER440000 FF, EC305201 SS+20d | 100% |  |  | ER445201 | ER445201 | 876 | 52 | 200 | LND | E | R | ER44 | 5201 | 4 | LND | 200 | E |  |  |  |  |
|  | E | **E Electrical** |  |  | 2008-10-06 | 2010-08-13 |  |  |  |  |  |  |  |  |  |  |  |  |  |  |  |  |  |  |  |  |  |  |
| EE46520105 |  | CA52 SR5201 - prelim Loads for Struc Steel |  | 10d | 2008-10-06 A | 2008-10-17 A | F3060 FF | 100% |  |  | EE46520105 | EE46520105 | 874 | 52 |  | LND | E | E | EE11 | 5201 | E | LND |  | E |  |  |  |  |
| EE905201 |  | CA52 SR5201 - Earthing Details |  | 30d | 2009-05-07 A | 2009-06-19 A | EE901201 SS | 100% |  |  | EE905201 | EE905201 | 874 | 52 |  | LND | E | E | EE90 | 5201 | E | LND |  | E |  |  |  |  |
| EE46520110 |  | CA52 SR5201 - El. CableTray Layout Pl. 1st Issue |  | 172d | 2009-12-07 A | 2010-08-13 A | F4040 FF+25d, EE460000 | 100% |  |  | EE46520110 | EE46520110 | 874 | 52 |  | LEI | E | E | EE46 | 5201 | E | LND |  | E |  |  |  |  |
| EE565201 |  | CA52 SR5201 - Cable Pulling Details |  | 159d | 2009-12-10 A | 2010-07-30 A | EE46520110 FF, EE500130 | 100% |  |  | EE565201 | EE565201 | 874 | 52 |  | LEI | E | E | EE56 | 5201 | E | LND |  | E |  |  |  |  |
| EE765201 |  | CA52 SR5201 - Layout Plan Light.& Sockets 1st Issue |  | 140d | 2010-01-26 A | 2010-08-13 A | EE000180 FS+10d | 100% |  |  | EE765201 | EE765201 | 874 | 52 |  | LEI | E | E | EE76 | 5201 | E | LND |  | E |  |  |  |  |
| EE46520108 |  | CA52 SR5201 - Final Loads for Struc Steel |  | 28d | 2010-03-22 A | 2010-04-30 A | EE46520105 | 100% |  |  | EE46520108 | EE46520108 | 874 | 52 |  | LEI | E | E | EE12 | 5201 | E | LND |  | E |  |  |  |  |
|  | J | **J Instrumentation** |  |  | 2008-10-06 | 2010-08-13 |  |  |  |  |  |  |  |  |  |  |  |  |  |  |  |  |  |  |  |  |  |  |
| EJ46520105 |  | CA52 SR5201 - prelim Loads for Struc Steel |  | 15d | 2008-10-06 A | 2008-10-24 A | F3060 FF | 100% |  |  | EJ46520105 | EJ46520105 | 86E | 52 |  | LND | E | J | EJ11 | 5201 | I | LND |  | E | 999 |  |  |  |
| EJ46520110 |  | CA52 SR5201 - Instr Cable Tray Layout Plans 1st Issue |  | 116d | 2010-03-01 A | 2010-08-13 A | F4460, EE46520110 FF, F4040 FF | 100% |  |  | EJ46520110 | EJ46520110 | 86E | 52 |  | LEI | E | J | EJ41 | 5201 | I | LND |  | E | 999 |  |  |  |
| EJ46520108 |  | CA52 SR5201 - Final Loads for Struc Steel |  | 10d | 2010-04-19 A | 2010-04-30 A | EJ46520105 | 100% |  |  | EJ46520108 | EJ46520108 | 86E | 52 |  | LEI | E | J | EJ12 | 5201 | I | LND |  | E | 999 |  |  |  |
|  | 53 | **53 CA53 - Piperack (between CA14/51)** |  |  | 2009-06-02 | 2011-11-24 |  |  |  |  |  |  |  |  |  |  |  |  |  |  |  |  |  |  |  |  |  |  |
|  | 5301 | **5301 Pipe Rack 3 - CA53** |  |  | 2009-06-02 | 2011-11-24 |  |  |  |  |  |  |  |  |  |  |  |  |  |  |  |  |  |  |  |  |  |  |
|  | C | **C Civil** |  |  | 2010-11-19 | 2011-04-21 |  |  |  |  |  |  |  |  |  |  |  |  |  |  |  |  |  |  |  |  |  |  |
| EC225301 |  | CA53 PR5301 - Layout Drwg / Loads IFD |  | 15d | 2010-11-19 A | 2010-12-09 A | EC440000 FF, EN255301 FF+8d | 100% |  |  | EC225301 | EC225301 | 87A | 53 | 200 | LND | E | C | EC22 | 5301 | de | LND |  |  | 5300C01 | FL |  |  |
| EC45530105 |  | CA53 PR5301 - Civil Layout drwgs AFC |  | 77d | 2010-12-01 A | 2011-03-21 A | EC225301, EC265301 SS | 100% |  |  | EC45530105 | EC45530105 | 87A | 53 | 200 | AVR | E | C | EC45 | 5301 | ar | LND |  | E | 5301C13 | FL |  |  |
| EC28530105 |  | CA53 SR5301 - Precast Layout drwgs AFC |  | 95d | 2010-12-08 A | 2011-04-21 A | EC155301 SS+5d, IMS-E-000140 FF | 100% |  |  | EC28530105 | EC28530105 | 87A | 53 | 200 | AVR | E | C | EC28 | 5301 | cq | LND | 200 | E | 5301C31 |  |  |  |
| EC28530106 |  | CA53 SR5301 - Precast Formw/Reinf. drwgs AFC |  | 95d | 2010-12-08 A | 2011-04-21 A | EC28530105 FF, IMS-E-000140 FF, IMS-E-000160 FF | 100% |  |  | EC28530106 | EC28530106 | 87A | 53 | 200 | AVR | E | C | EC28 | 5301 | cq | LND | 200 | E | 5301C53 |  |  |  |
| EC155301 |  | CA53 PR5301 - Piling drwgs AFC |  | 65d | 2010-12-10 A | 2011-03-14 A | EC265301 SS, IMS-E-000130 FF | 100% | start on or after 2010-12-10 |  | EC155301 | EC155301 | 87A | 53 | 200 | AVR | E | C | EC15 | 5301 | PI | LND |  |  | 5301C16 | FL |  |  |
| EC265301 |  | CA53 PR5301 - Civil Static Calc Fdtn |  | 65d | 2010-12-10 A | 2011-03-14 A | EC265104, EC225301 | 100% | start on or after 2010-12-10 |  | EC265301 | EC265301 | 87A | 53 | 200 | AVR | E | C | EC26 | 5301 | de | LND |  |  | 5301C14 | FL |  |  |
| EC285301 |  | CA53 PR5301 - Formw/Reinforce drwgs Found. AFC |  | 93d | 2010-12-10 A | 2011-04-21 A | EC155301 SS, EC265301 SS | 100% | start on or after 2010-12-10 |  | EC285301 | EC285301 | 87A | 53 | 200 | AVR | E | C | EC28 | 5301 | cq | LND |  |  | 5301C21 | FL |  |  |
| EC075305 |  | CA53 PR5301 - Issue of working drwgs (AFC) by RDI |  | 90d | 2010-12-15 A | 2011-04-21 A | EC28530105 FF, EC45530105 FF | 100% |  | TKB-B [1920 h] | EC075305 | EC075305 | 87A | 53 | 200 | AVR | E | C | EC07 | 5301 | cq | LND |  | E | 1010C13 | FL | 1920,00 | 999 |
| EC075300 |  | CA53 PR5301 - Check & Release of working drwgs (AFC) |  | 45d | 2010-12-27 A | 2011-02-28 A | EC45530105 SS+10d | 100% |  | TKB-B [184 h] | EC075300 | EC075300 | 87A | 53 | 200 | LND | E | C | EC07 | 5301 | cq | LND |  | E |  | FL | 184,00 | 999 |

Notes:
- EC225301: P3 Activity Log Info: TKB-B Keyplan to Subcontractor
- EC45530105: P3 Activity Log Info: incl. PMT approval

| ID | WBS | Activity | Type | Duration | Start | Finish | Predecessors | Complete | Total float | Constraint | Resources | TB26 Ressource Budget | UDF_SAVE ACTID | UDF_SAVE ACT ID | Department | Type of Work | Constr. Area | Inquiry/Order No | PMT-Area | PMT-Schedule Org | PMT-Discipline | PMT-Phase | PMT-Respons. | Zeigen/n. Zeigen | WBS Phase | WBS Discipline | WBS Type of Work | WBS Objects | IMS | UPT |
| --- | --- | --- | --- | --- | --- | --- | --- | --- | --- | --- | --- | --- | --- | --- | --- | --- | --- | --- | --- | --- | --- | --- | --- | --- | --- | --- | --- | --- | --- | --- |
|  | N | **N Structural Steel** |  |  | 2010-08-23 | 2011-05-17 |  |  |  |  |  |  |  |  |  |  |  |  |  |  |  |  |  |  |  |  |  |  |  |  |
| EN155301 |  | CA53 PR5301 - CAD Model/Concepts StrSteel |  | 37d | 2010-08-23 A | 2010-10-12 A | E3A1840 FF+10d | 100% |  |  | TKB-S [640 h] | 640,00 | EN155301 | EN155301 | 87B | N01F | 53 | N01F | 200 | 200 | 055 | E | LEI | FL | E | N | EN15 | 5301 | de | LND |
| EN21530105 |  | CA53 PR5301 - GA-Drwgs + Fdtn Loads |  | 42d | 2010-08-30 A | 2010-10-26 A | EJ46530105, ER165301, EN155301 FF+10d, EE46530105 | 100% |  |  | TKB-S [480 h] | 480,00 | EN21530105 | EN21530105 | 87B | N01F | 53 | N01F | 200 |  |  |  | LEI | FL | E | N | EN21 | 5301 | de | LND |
| EN265301 |  | CA53 PR5301 - Layout dwgs input for KM dwgs |  | 107d | 2010-10-18 A | 2011-03-18 A | EN24530110 FF+5d | 100% |  |  | TKB-S [1040 h] | 1040,00 | EN265301 | EN265301 | 87B | N01F | 53 | N01F | 200 |  |  |  | LEI | FL | E | N | EN26 | 5301 | st | LND |
| EN24530105 |  | CA53 PR5301 - Static Calc for Fdtn Loads |  | 49d | 2010-10-27 A | 2011-01-06 A | EN21530105 | 100% |  |  |  |  | EN24530105 | EN24530105 | 87B | N01F | 53 | N01F | 200 |  |  |  | LEI | FL | E | N | EN24 | 5301 | de | LND |
| EN21530110 |  | CA53 PR5301 - GA-Drwgs + Final Loads |  | 43d | 2010-12-20 A | 2011-02-18 A | EN24530105, EE46530108, EN21530105 FS+10d, ER425301 SS, EJ46530108 FS+10d | 100% |  |  | TKB-S [640 h] | 640,00 | EN21530110 | EN21530110 | 87B | N01F | 53 | N01F | 200 |  |  |  | LEI | FL | E | N | EN21 | 5301 | de | LND |
| EN255301 |  | CA53 PR5301 - Loads for Civil | milestone | 0d | 2011-01-07 A | 2011-01-07 A | EN24530105 FF | 100% |  | finish on or after 2011-01-07 |  |  | EN255301 | EN255301 | 87B | N01F | 53 | N01F | 200 | 200 | 055 | E | LEI | FL | E | N | EN25 | 5301 | de | LND |
| EN24530110 |  | CA53 PR5301 - Final Static Calc |  | 15d | 2011-02-21 A | 2011-03-11 A | EN21530110 FF+10d | 100% |  | finish on or after 2011-03-11 |  |  | EN24530110 | EN24530110 | 87B | N01F | 53 | N01F | 200 |  |  |  | LEI | FL | E | N | EN24 | 5301 | de | LND |
| EN27530105 |  | CA53 PR5301 - KM drwgs |  | 20d | 2011-03-21 A | 2011-04-15 A | EN24530105, EN265301 | 100% |  |  | KM Drwgs preparation by Cheljabinsk [110 t] | 0,00 | EN27530105 | EN27530105 | 87B | N01F | 53 | N01F | 200 |  |  |  | Chel | FL | E | N | EN27 | 5301 | de | LND |
| EN285301 |  | CA53 PR5301 - Shop dwgs(KMD) by Vendor |  | 35d | 2011-03-30 A | 2011-05-17 A | EN27530110 FF+12d | 100% |  |  |  |  | EN285301 | EN285301 | 87B | N01F | 53 | N01F | 200 |  |  |  | SC | FL | E | N | EN28 | 5301 | de | LND |
| EN27530110 |  | CA53 PR5301 - Check KM drwgs |  | 10d | 2011-04-18 A | 2011-04-29 A | EN27530105 | 100% |  |  |  |  | EN27530110 | EN27530110 | 87B | N01F | 53 | N01F | 200 |  |  |  | LEI | FL | E | N | EN27 | 5301 | de | LND |
|  | R | **R Piping** |  |  | 2009-06-02 | 2011-05-05 |  |  |  |  |  |  |  |  |  |  |  |  |  |  |  |  |  |  |  |  |  |  |  |  |
| ER155301 |  | CA53 PR5301 - Conceptual Piping |  | 328d | 2009-06-02 A | 2010-09-15 A | F2760 | 100% |  |  |  |  | ER155301 | ER155301 | 876 |  | 53 |  | 200 |  |  |  | LND | FL | E | R | ER15 | 5301 | PL | LND |
| ER305301 |  | CA53 PR5301 - CAD Model Piping / Equipment |  | 314d | 2009-10-29 A | 2011-01-27 A | ER155301 SS, ER365301 FF+5d, ER395301 FF+5d | 100% |  |  |  |  | ER305301 | ER305301 | 876 |  | 53 |  | 200 |  |  |  | LNI | FL | E | R | ER30 | 5301 | PL | LND |
| ER165301 |  | CA53 PR5301 - prelim Loads for Struc Steel |  | 20d | 2010-08-19 A | 2010-09-15 A | ER155301 FF | 100% |  |  |  |  | ER165301 | ER165301 | 876 |  | 53 |  | 200 |  |  |  | LND | FL | E | R | ER16 | 5301 | PL | LND |
| ER445301 |  | CA53 PR5301 - Piping Isometrics (UG) |  | 20d | 2010-10-11 A | 2010-11-05 A | EC305301 SS+20d, ER440000 FF | 100% |  |  |  |  | ER445301 | ER445301 | 876 |  | 53 |  | 200 | 200 |  | E | LND | FL | E | R | ER44 | 5301 | 4 | LND |
| ER475301 |  | CA53 PR5301 - Piping Layout drwgs |  | 66d | 2010-10-25 A | 2011-01-27 A | ER395301 FF+5d, ER305301 FF | 100% |  |  |  |  | ER475301 | ER475301 | 876 |  | 53 |  | 200 |  |  |  | LEI | FL | E | R | ER47 | 5301 | 5 | LND |
| ER425301 |  | CA53 PR5301 - Stress Calculation / Final Loads |  | 105d | 2010-12-08 A | 2011-05-05 A | F4045 FF | 100% |  | as late as possible |  |  | ER425301 | ER425301 | 872 |  | 53 |  | 200 |  |  |  | LND | FL | E | R | ER42 | 5301 | PL | LND |
| ER455301 |  | CA53 PR5301 - Piping Isometrics |  | 95d | 2010-12-22 A | 2011-05-05 A | ER395301 FF, ER305301 FF+5d, ER425301 FF | 100% |  | as late as possible |  |  | ER455301 | ER455301 | 876 |  | 53 |  | 200 |  |  |  | LEI | FL | E | R | ER45 | 5301 | 5 | LND |
| ER495301 |  | CA53 PR5301 - Design Check / Release Isos & BOM |  | 90d | 2010-12-30 A | 2011-05-05 A | ER455301 FF, IMS-E-000110 FF | 100% |  |  |  |  | ER495301 | ER495301 | 876 |  | 53 |  | 200 |  |  |  | LEI | FL | E | R | ER49 | 5301 | 5 | LND |
| ER365301 |  | CA53 PR5301 - CAD Model Review 60% |  | 3d | 2011-01-18 A | 2011-01-20 A | ER365104 FF, F4045 FF | 100% |  |  |  |  | ER365301 | ER365301 | 876 |  | 53 |  | 200 |  |  |  | LND | FL | E | R | ER36 | 5301 | 2 | LND |
| ER395301 |  | CA53 PR5301 - CAD Model Review 90% |  | 3d | 2011-01-18 A | 2011-01-20 A | F4468 FF | 100% |  |  |  |  | ER395301 | ER395301 | 876 |  | 53 |  | 200 |  |  |  | LND | FL | E | R | ER39 | 5301 | 3 | LND |
| ER195301 |  | CA53 PR5301 - Final Loads for Struc Steel | milestone | 0d | 2011-02-07 A | 2011-02-07 A | EN21530110 FF-10d, ER165301 FF | 100% |  |  |  |  | ER195301 | ER195301 | 876 |  | 53 |  | 200 |  |  |  | LNI | FL | E | R | ER19 | 5301 | PL | LND |
|  | E | **E Electrical** |  |  | 2009-06-22 | 2011-11-24 |  |  |  |  |  |  |  |  |  |  |  |  |  |  |  |  |  |  |  |  |  |  |  |  |
| EE905301 |  | CA53 PR5301 - Earthing Details |  | 30d | 2009-06-22 A | 2009-07-31 A | EE905104 | 100% |  |  |  |  | EE905301 | EE905301 | 874 |  | 53 |  |  |  |  | E | LND | FL | E | E | EE90 | 5301 | E | LND |
| EE46530110 |  | CA53 PR5301 - El. CableTray Layout Pl. 1st Issue |  | 261d | 2009-12-07 A | 2010-12-17 A | F4040 FF+25d | 100% |  |  |  |  | EE46530110 | EE46530110 | 874 |  | 53 |  |  |  |  | E | LEI | FL | E | E | EE46 | 5301 | E | LND |
| EE565301 |  | CA53 PR5301 - Cable Pulling Details |  | 297d | 2009-12-10 A | 2011-02-14 A | EE500130, EE46530110 FF | 100% |  |  |  |  | EE565301 | EE565301 | 874 |  | 53 |  |  |  |  | E | LEI | FL | E | E | EE56 | 5301 | E | LND |
| EE765301 |  | CA53 PR5301 - Layout Plan Light.& Sockets 1st Issue |  | 249d | 2010-01-26 A | 2011-01-18 A | EE000180 FS+10d | 100% |  |  |  |  | EE765301 | EE765301 | 874 |  | 53 |  |  |  |  | E | LEI | FL | E | E | EE76 | 5301 | E | LND |
| EE46530105 |  | CA53 PR5301 - prelim Loads for Struc Steel |  | 19d | 2010-08-19 A | 2010-09-14 A | ER14000 FF | 100% |  |  |  |  | EE46530105 | EE46530105 | 874 |  | 53 |  |  |  |  | E | LND | FL | E | E | EE11 | 5301 | E | LND |
| EE46530108 |  | CA53 PR5301 - Final Loads for Struc Steel |  | 20d | 2010-11-22 A | 2010-12-17 A | EE46530110 FF | 100% |  |  |  |  | EE46530108 | EE46530108 | 874 |  | 53 |  |  |  |  | E | LEI | FL | E | E | EE12 | 5301 | E | LND |
| EE76181010 |  | CA18 Chiller Unit Area - Layout Plan Light.& Sockets |  | 45d | 2011-09-21 | 2011-11-24 | F4475 FF+20d |  | 392.5d |  |  |  | EE765301 | EE76181010 | 874 |  | 18 |  |  |  |  | E | LEI | FL | E | E | EE76 | 1810 | E | LND |

| ID | WBS | Activity | Type | Duration | Start | Finish | Predecessors | Complete | Resources | UDF_SAVE ACTID | UDF_SAVE ACT ID | Department | Constr. Area | Pro Unit/DocCode | PMT-Phase | PMT-Respons. | Zeigen/n. Zeigen | WBS Phase | WBS Discipline | WBS Type of Work | WBS Objects | IMS | UPT | PMT-Area | TB26 Ressource Budget | Inquiry/Order No | Type of Work | PMT-Schedule Org | PMT-Discipline |
| --- | --- | --- | --- | --- | --- | --- | --- | --- | --- | --- | --- | --- | --- | --- | --- | --- | --- | --- | --- | --- | --- | --- | --- | --- | --- | --- | --- | --- | --- |
|  | J | **J Instrumentation** |  |  | 2009-12-21 | 2010-12-17 |  |  |  |  |  |  |  |  |  |  |  |  |  |  |  |  |  |  |  |  |  |  |  |
| EJ46530105 |  | CA53 PR5301 - prelim Loads for Struc Steel |  | 131d | 2009-12-21 A | 2010-07-01 A | F3060 | 100% |  | EJ46530105 | EJ46530105 | 86E | 53 | 999 | E | LND | FL | E | J | EJ11 | 5301 | I | LND |  |  |  |  |  |  |
| EJ46530110 |  | CA53 PR5301 - Instr Cable Tray Layout Plans 1st Issue |  | 205d | 2010-03-01 A | 2010-12-17 A | F4040 FF, EE46530110 FF, F4460 | 100% |  | EJ46530110 | EJ46530110 | 86E | 53 | 999 | E | LEI | FL | E | J | EJ41 | 5301 | I | LND |  |  |  |  |  |  |
| EJ46530108 |  | CA53 PR5301 - Final Loads for Struc Steel |  | 10d | 2010-11-22 A | 2010-12-03 A | EJ46530105 | 100% |  | EJ46530108 | EJ46530108 | 86E | 53 | 999 | E | LEI | FL | E | J | EJ12 | 5301 | I | LND |  |  |  |  |  |  |
|  | 54 | **54 CA54 - Piperack (between CA15/16/51/55)** |  |  | 2008-03-03 | 2011-01-31 |  |  |  |  |  |  |  |  |  |  |  |  |  |  |  |  |  |  |  |  |  |  |  |
|  | 5401 | **5401 Pipe Rack 4 - Part 1 - CA54** |  |  | 2008-03-03 | 2011-01-31 |  |  |  |  |  |  |  |  |  |  |  |  |  |  |  |  |  |  |  |  |  |  |  |
|  | C | **C Civil** |  |  | 2010-03-01 | 2010-09-20 |  |  |  |  |  |  |  |  |  |  |  |  |  |  |  |  |  |  |  |  |  |  |  |
| EC225401 |  | CA54 SR5401 - Layout Drwg / Loads IFD |  | 10d | 2010-03-01 A | 2010-03-12 A | EN255401 FF | 100% |  | EC225401 | EC225401 | 87A | 54 | 5400C01 |  | LND |  | E | C | EC22 | 5401 | de | LND | 200 |  |  |  |  |  |
| EC155401 |  | CA54 SR5401 - Piling drwgs AFC |  | 47d | 2010-03-15 A | 2010-05-21 A | EC265401 SS | 100% |  | EC155401 | EC155401 | 87A | 54 | 5401C16 |  | IPR |  | E | C | EC15 | 5401 | PI | LND | 200 |  |  |  |  |  |
| EC265401 |  | CA54 SR5401 - Civil Static Calc Fdtn |  | 132d | 2010-03-15 A | 2010-09-20 A | P3C0BD FS+40d, EC225401 | 100% |  | EC265401 | EC265401 | 87A | 54 | 5401C14 |  | IPR |  | E | C | EC26 | 5401 | de | LND | 200 |  |  |  |  |  |
| EC45540105 |  | CA54 SR5401 - Civil Layout drwgs AFC |  | 84d | 2010-03-15 A | 2010-07-14 A | AD2230, P3C0BD, EC225401, EC265401 SS | 100% |  | EC45540105 | EC45540105 | 87A | 54 | 5401C13 | E | IPR |  | E | C | EC45 | 5401 | ar | LND | 200 |  |  |  |  |  |
| EC285401 |  | CA54 SR5401 - Formw/Reinforce drwgs AFC |  | 79d | 2010-03-22 A | 2010-07-14 A | EC45540105 FF, EC265401 SS, EC155401 SS+5d | 100% |  | EC285401 | EC285401 | 87A | 54 | 5401C21 |  | IPR |  | E | C | EC28 | 5401 | cq | LND | 200 |  |  |  |  |  |
| EC075400 |  | CA54 SR5400 - Check & Release of working drwgs (AFC) |  | 93d | 2010-04-21 A | 2010-08-31 A | EC45540105 SS+25d, EC285401 FF+5d | 100% | TKB-B [120 h] | EC075400 | EC075400 | 87A | 54 |  | E | LND | FL | E | C | EC07 | 5401 | cq | LND | 200 | 120,00 | 999 |  |  |  |
| EC075405 |  | CA54 SR5400 - Issue of working drwgs (AFC) by RDI |  | 86d | 2010-04-21 A | 2010-08-20 A | EC285402 FF, EC265401 FF, EC285401, EC45540105 FF | 100% | TKB-B [880 h] | EC075405 | EC075405 | 87A | 54 | 1010C13 | E | IPR | FL | E | C | EC07 | 5401 | cq | LND | 200 | 880,00 | 999 |  |  |  |
|  | N | **N Structural Steel** |  |  | 2008-03-03 | 2010-12-20 |  |  |  |  |  |  |  |  |  |  |  |  |  |  |  |  |  |  |  |  |  |  |  |
| EN155401 |  | CA54 SR5401 - CAD Model/Concepts StrSteel |  | 126d | 2008-03-03 A | 2008-08-29 A | AD2230 FF | 100% |  | EN155401 | EN155401 | 87B | 54 |  | E | LND | 0 | E | N | EN15 | 5401 | de | LND | 200 |  | N01G | N01G | 200 | 055 |
| EN21540105 |  | CA54 SR5401 - GA-Drwgs + Fdtn Loads |  | 15d | 2009-02-23 A | 2009-03-13 A | EE46540105, EJ46540105, AD2230 FS+40d, EN155401 FF, ER165401 | 100% |  | EN21540105 | EN21540105 | 87B | 54 |  |  | LND |  | E | N | EN21 | 5401 | de | LND | 200 |  | N01G | N01G |  |  |
| EN24540105 |  | CA54 SR5401 - Static Calc for Fdtn Loads |  | 41d | 2009-12-30 A | 2010-02-26 A | EN21540105 | 100% | TKB-S [240 h] | EN24540105 | EN24540105 | 87B | 54 |  |  | LND |  | E | N | EN24 | 5401 | de | LND | 200 | 240,00 | N01G | N01G |  |  |
| EN21540110 |  | CA54 SR5401 - GA-Drwgs + Final Loads |  | 132d | 2010-01-18 A | 2010-07-26 A | EN24540105, EJ46540108 FF, EE46540108 FF, EN21540105 FS+15d, ER425401, F4030 FS+15d | 100% | TKB-S [320 h] | EN21540110 | EN21540110 | 87B | 54 |  |  | LEI |  | E | N | EN21 | 5401 | de | LND | 200 | 320,00 | N01G | N01G |  |  |
| EN255401 |  | CA54 SR5401 - Loads for Civil | milestone | 0d | 2010-02-26 A | 2010-02-26 A | EN24540105 FF | 100% |  | EN255401 | EN255401 | 87B | 54 |  | E | LND | 0 | E | N | EN25 | 5401 | de | LND | 200 |  | N01G | N01G | 200 | 055 |
| EN24540110 |  | CA54 SR5401 - Final Static Calc |  | 86d | 2010-04-09 A | 2010-08-10 A | EN21540110 FF+5d, ER195401 FF | 100% | TKB-S [320 h] | EN24540110 | EN24540110 | 87B | 54 |  |  | LEI |  | E | N | EN24 | 5401 | de | LND | 200 | 320,00 | N01G | N01G |  |  |
| EN675401 |  | CA54 SR5401 - Grating Cut-Out drwgs |  | 111d | 2010-05-28 A | 2010-10-29 A | EN265401 FS+10d, F4460 FF+10d, ER425401 FF | 100% | TKB-S [240 h] | EN675401 | EN675401 | 87B | 54 |  | C | LND |  | E | N | EN67 | 5401 | de | LND | 200 | 240,00 | N01G | N01G | 200 |  |
| EN265401 |  | CA54 SR5401 - Layout dwgs input for KM dwgs |  | 56d | 2010-06-01 A | 2010-08-17 A | F4030 FF+20d, EN24540110 FF+5d | 100% | TKB-S [800 h] | EN265401 | EN265401 | 87B | 54 |  |  | LEI |  | E | N | EN26 | 5401 | st | LND | 200 | 800,00 | N01G | N01G |  |  |
| EN27540105 |  | CA54 SR5401 - KM drwgs |  | 30d | 2010-08-18 A | 2010-09-28 A | EN24540105, P3N01D, EN265401 | 100% | KM Drwgs preparation by Cheljabinsk [155 t] | EN27540105 | EN27540105 | 87B | 54 |  |  | Chel |  | E | N | EN27 | 5401 | de | LND | 200 | 0,00 | N01G | N01G |  |  |
| EN27540110 |  | CA54 SR5401 - Check KM drwgs |  | 10d | 2010-09-29 A | 2010-10-12 A | EN27540105 | 100% |  | EN27540110 | EN27540110 | 87B | 54 |  |  | LEI |  | E | N | EN27 | 5401 | de | LND | 200 |  | N01G | N01G |  |  |
| EN285401 |  | CA54 SR5401 - Shop dwgs(KMD) by Vendor |  | 43d | 2010-10-20 A | 2010-12-20 A | EN27540110 | 100% |  | EN285401 | EN285401 | 87B | 54 |  |  | Chel |  | E | N | EN28 | 5401 | de | LND | 200 |  | N01G | N01G |  |  |
| EN645401 |  | CA54 SR5401 - Check Grating Cut-Out drwgs |  | 23d | 2010-10-20 A | 2010-11-22 A | EN675401 | 100% |  | EN645401 | EN645401 | 87B | 54 |  | C | LND |  | E | N | EN67 | 5401 | de | LND | 200 |  | N01G | N01G | 200 |  |
| EN685401 |  | CA54 SR5401 - Grating Fabrication drwgs |  | 23d | 2010-10-20 A | 2010-11-22 A | EN675401, EN645401 FF | 100% |  | EN685401 | EN685401 | 87B | 54 |  | C | Chel |  | E | N | EN68 | 5401 | de | LND | 200 |  | N01G | N01G | 200 |  |

Notes:
- EC225401: P3 Activity Log Info: TKB-B Keyplan to Subcontractor
- EC45540105: P3 Activity Log Info: incl. PMT approval

| ID | WBS | Activity | Type | Duration | Start | Finish | Predecessors | Complete | UDF_SAVE ACTID | UDF_SAVE ACT ID | Department | Constr. Area | PMT-Area | PMT-Respons. | WBS Phase | WBS Discipline | WBS Type of Work | WBS Objects | IMS | UPT | PMT-Schedule Org | PMT-Phase | Pro Unit/DocCode |
| --- | --- | --- | --- | --- | --- | --- | --- | --- | --- | --- | --- | --- | --- | --- | --- | --- | --- | --- | --- | --- | --- | --- | --- |
|  | R | **R Piping** |  |  | 2008-04-01 | 2011-01-31 |  |  |  |  |  |  |  |  |  |  |  |  |  |  |  |  |  |
| ER155401 |  | CA54 SR5401 - Conceptual Piping |  | 169d | 2008-04-01 A | 2008-11-28 A | F2760 | 100% | ER155401 | ER155401 | 876 | 54 | 200 | LND | E | R | ER15 | 5401 | PL | LND |  |  |  |
| ER305401 |  | CA54 SR5401 - CAD Model Piping / Equipment |  | 538d | 2008-06-02 A | 2010-07-23 A | ER395401 FF+10d, ER365401 FF+20d, ER155401 SS | 100% | ER305401 | ER305401 | 876 | 54 | 200 | LNI | E | R | ER30 | 5401 | PL | LND |  |  |  |
| ER165401 |  | CA54 SR5401 - prelim Loads for Struc Steel |  | 20d | 2009-01-05 A | 2009-01-30 A | ER155401 FF | 100% | ER165401 | ER165401 | 876 | 54 | 200 | LND | E | R | ER16 | 5401 | PL | LND |  |  |  |
| ER425401 |  | CA54 SR5401 - Stress Calculation / Final Loads |  | 98d | 2009-11-16 A | 2010-04-09 A | F4030 FF | 100% | ER425401 | ER425401 | 872 | 54 | 200 | LND | E | R | ER42 | 5401 | PL | LND |  |  |  |
| ER195401 |  | CA54 SR5401 - Final Loads for Struc Steel | milestone | 0d | 2010-01-04 A | 2010-01-04 A | ER165401 FF, EN21540110 SF-5d, F4030 FF+5d | 100% | ER195401 | ER195401 | 876 | 54 | 200 | LNI | E | R | ER19 | 5401 | PL | LND |  |  |  |
| ER365401 |  | CA54 SR5401 - CAD Model Review 60% |  | 15d | 2010-03-01 A | 2010-03-19 A | F4040 SS | 100% | ER365401 | ER365401 | 876 | 54 | 200 | LND | E | R | ER36 | 5401 | 2 | LND |  |  |  |
| ER395401 |  | CA54 SR5401 - CAD Model Review 90% |  | 10d | 2010-06-28 A | 2010-07-09 A | F4460 FF | 100% | ER395401 | ER395401 | 876 | 54 | 200 | LND | E | R | ER39 | 5401 | 3 | LND |  |  |  |
| ER455401 |  | CA54 SR5401 - Piping Isometrics |  | 69d | 2010-08-16 A | 2010-11-19 A | ER395401 FS+25d, ER305401 FF+15d, ER425401 | 100% | ER455401 | ER455401 | 876 | 54 | 200 | LEI | E | R | ER45 | 5401 | 5 | LND |  |  |  |
| ER475401 |  | CA54 SR5401 - Piping Layout drwgs |  | 87d | 2010-09-17 A | 2011-01-20 A | ER475101 FF+18d, ER305401, ER395401 FF+20d | 100% | ER475401 | ER475401 | 876 | 54 | 200 | LEI | E | R | ER47 | 5401 | 5 | LND |  |  |  |
| ER445401 |  | CA54 SR5401 - Piping Isometrics (UG) |  | 25d | 2010-10-04 A | 2010-11-05 A | ER440000 FF, EC305401 SS+20d | 100% | ER445401 | ER445401 | 876 | 54 | 200 | LND | E | R | ER44 | 5401 | 4 | LND | 200 | E |  |
| ER495401 |  | CA54 SR5401 - Design Check / Release Isos & BOM |  | 79d | 2010-10-08 A | 2011-01-31 A | ER455401 FF | 100% | ER495401 | ER495401 | 876 | 54 | 200 | LEI | E | R | ER49 | 5401 | 5 | LND |  |  |  |
|  | E | **E Electrical** |  |  | 2008-10-06 | 2010-10-15 |  |  |  |  |  |  |  |  |  |  |  |  |  |  |  |  |  |
| EE46540105 |  | CA54 SR5401 - prelim Loads for Struc Steel |  | 10d | 2008-10-06 A | 2008-10-17 A | F3060 FF | 100% | EE46540105 | EE46540105 | 874 | 54 |  | LND | E | E | EE11 | 5401 | E | LND |  | E |  |
| EE905401 |  | CA54 SR5401 - Earthing Details |  | 30d | 2009-05-07 A | 2009-06-19 A | EE901201 SS, EE900070 | 100% | EE905401 | EE905401 | 874 | 54 |  | LND | E | E | EE90 | 5401 | E | LND |  | E |  |
| EE565401 |  | CA54 SR5401 - Cable Pulling Details |  | 164d | 2009-12-03 A | 2010-07-30 A | EE46540110 FF, EE500130 | 100% | EE565401 | EE565401 | 874 | 54 |  | LEI | E | E | EE56 | 5401 | E | LND |  | E |  |
| EE46540110 |  | CA54 SR5401 - El. CableTray Layout Pl. 1st Issue |  | 197d | 2009-12-07 A | 2010-09-17 A | F4030 FF+75d, EE460000 | 100% | EE46540110 | EE46540110 | 874 | 54 |  | LEI | E | E | EE46 | 5401 | E | LND |  | E |  |
| EE765401 |  | CA54 SR5401 - Layout Plan Light.& Sockets 1st Issue |  | 185d | 2010-01-26 A | 2010-10-15 A | EE000180 FS+10d | 100% | EE765401 | EE765401 | 874 | 54 |  | LEI | E | E | EE76 | 5401 | E | LND |  | E |  |
| EE46540108 |  | CA54 SR5401 - Final Loads for Struc Steel |  | 37d | 2010-02-22 A | 2010-04-15 A | EE46540105 | 100% | EE46540108 | EE46540108 | 874 | 54 |  | LEI | E | E | EE12 | 5401 | E | LND |  | E |  |
|  | J | **J Instrumentation** |  |  | 2008-10-06 | 2010-09-17 |  |  |  |  |  |  |  |  |  |  |  |  |  |  |  |  |  |
| EJ46540105 |  | CA54 SR5401 - prelim Loads for Struc Steel |  | 15d | 2008-10-06 A | 2008-10-24 A | F3060 FF | 100% | EJ46540105 | EJ46540105 | 86E | 54 |  | LND | E | J | EJ11 | 5401 | I | LND |  | E | 999 |
| EJ46540110 |  | CA54 SR5401 - Instr Cable Tray Layout Plans 1st Issue |  | 141d | 2010-03-01 A | 2010-09-17 A | F4030 FF, F4460, EE46540110 FF | 100% | EJ46540110 | EJ46540110 | 86E | 54 |  | LEI | E | J | EJ41 | 5401 | I | LND |  | E | 999 |
| EJ46540108 |  | CA54 SR5401 - Final Loads for Struc Steel |  | 10d | 2010-03-31 A | 2010-04-15 A | EJ46540105 | 100% | EJ46540108 | EJ46540108 | 86E | 54 |  | LEI | E | J | EJ12 | 5401 | I | LND |  | E | 999 |
|  | 5402 | **5402 Pipe Rack 4 - Part 2 - CA54** |  |  | 2008-03-03 | 2011-01-31 |  |  |  |  |  |  |  |  |  |  |  |  |  |  |  |  |  |
|  | C | **C Civil** |  |  | 2010-03-01 | 2010-09-20 |  |  |  |  |  |  |  |  |  |  |  |  |  |  |  |  |  |
| EC225402 |  | CA54 SR5402 - Layout Drwg / Loads IFD |  | 10d | 2010-03-01 A | 2010-03-12 A | EN255402 FF | 100% | EC225402 | EC225402 | 87A | 54 | 200 | LND | E | C | EC22 | 5402 | de | LND | 200 | E |  |
| EC155402 |  | CA54 SR5402 - Piling drwgs AFC |  | 47d | 2010-03-15 A | 2010-05-21 A | EC265402 SS | 100% | EC155402 | EC155402 | 87A | 54 | 200 | IPR | E | C | EC15 | 5402 | PI | LND |  |  | 5402C16 |
| EC265402 |  | CA54 SR5402 - Civil Static Calc Fdtn |  | 132d | 2010-03-15 A | 2010-09-20 A | P3C0BD, EC225402, EC265401 SS | 100% | EC265402 | EC265402 | 87A | 54 | 200 | IPR | E | C | EC26 | 5402 | de | LND | 200 | E | 5402C14 |
| EC45540205 |  | CA54 SR5402 - Civil Layout drwgs AFC |  | 84d | 2010-03-15 A | 2010-07-14 A | P3C0BD FS+10d, EC225402, AD2230, EC265402 SS | 100% | EC45540205 | EC45540205 | 87A | 54 | 200 | IPR | E | C | EC45 | 5402 | ar | LND |  | E | 5402C13 |
| EC285402 |  | CA54 SR5402 - Formw/Reinforce drwgs AFC |  | 79d | 2010-03-22 A | 2010-07-14 A | EC45540205 FF, EC265402 SS, EC155402 SS+5d | 100% | EC285402 | EC285402 | 87A | 54 | 200 | IPR | E | C | EC28 | 5402 | cq | LND | 200 | E | 5402C21 |

Notes:
- EC225402: P3 Activity Log Info: TKB-B Keyplan to Subcontractor
- EC45540205: P3 Activity Log Info: incl. PMT approval

| ID | WBS | Activity | Type | Duration | Start | Finish | Predecessors | Complete | Resources | UDF_SAVE ACTID | UDF_SAVE ACT ID | Department | Type of Work | Constr. Area | Inquiry/Order No | PMT-Area | PMT-Schedule Org | PMT-Discipline | PMT-Phase | PMT-Respons. | Zeigen/n. Zeigen | WBS Phase | WBS Discipline | WBS Type of Work | WBS Objects | IMS | UPT | TB26 Ressource Budget |
| --- | --- | --- | --- | --- | --- | --- | --- | --- | --- | --- | --- | --- | --- | --- | --- | --- | --- | --- | --- | --- | --- | --- | --- | --- | --- | --- | --- | --- |
|  | N | **N Structural Steel** |  |  | 2008-03-03 | 2011-01-07 |  |  |  |  |  |  |  |  |  |  |  |  |  |  |  |  |  |  |  |  |  |  |
| EN155402 |  | CA54 SR5402 - CAD Model/Concepts StrSteel |  | 126d | 2008-03-03 A | 2008-08-29 A | EN155401 FF | 100% |  | EN155402 | EN155402 | 87B | N01H | 54 | N01H | 200 | 200 | 055 | E | LND | 0 | E | N | EN15 | 5402 | de | LND |  |
| EN21540205 |  | CA54 SR5402 - GA-Drwgs + Fdtn Loads |  | 15d | 2009-02-23 A | 2009-03-13 A | EJ46540205, AD2230 FS+40d, ER165402, EN21540105 FF, EN155402 FF, EE46540205 | 100% |  | EN21540205 | EN21540205 | 87B | N01H | 54 | N01H | 200 |  |  |  | LND |  | E | N | EN21 | 5402 | de | LND |  |
| EN24540205 |  | CA54 SR5402 - Static Calc for Fdtn Loads |  | 31d | 2009-12-30 A | 2010-02-12 A | EN24540105 SS+5d, EN21540205 FS+10d | 100% | TKB-S [240 h] | EN24540205 | EN24540205 | 87B | N01H | 54 | N01H | 200 |  |  |  | LND |  | E | N | EN24 | 5402 | de | LND | 240,00 |
| EN21540210 |  | CA54 SR5402 - GA-Drwgs + Final Loads |  | 137d | 2010-01-18 A | 2010-08-02 A | EN24540205, EE46540208 FF, ER425402, EJ46540208 FF, F4030 FS+20d, EN21540205 FS+15d | 100% | TKB-S [320 h] | EN21540210 | EN21540210 | 87B | N01H | 54 | N01H | 200 |  |  |  | LEI |  | E | N | EN21 | 5402 | de | LND | 320,00 |
| EN255402 |  | CA54 SR5402 - Loads for Civil | milestone | 0d | 2010-02-12 A | 2010-02-12 A | EN24540205 FF | 100% |  | EN255402 | EN255402 | 87B | N01H | 54 | N01H | 200 | 200 | 055 | E | LND | 0 | E | N | EN25 | 5402 | de | LND |  |
| EN24540210 |  | CA54 SR5402 - Final Static Calc |  | 101d | 2010-04-09 A | 2010-08-31 A | ER195402 FF, EN21540210 FS-5d | 100% | TKB-S [320 h] | EN24540210 | EN24540210 | 87B | N01H | 54 | N01H | 200 |  |  |  | LEI |  | E | N | EN24 | 5402 | de | LND | 320,00 |
| EN265402 |  | CA54 SR5402 - Layout dwgs input for KM dwgs |  | 20d | 2010-08-02 A | 2010-08-27 A | EN24540210 FF+10d, F4030 FF+20d | 100% | TKB-S [640 h] | EN265402 | EN265402 | 87B | N01H | 54 | N01H | 200 |  |  |  | LEI |  | E | N | EN26 | 5402 | st | LND | 640,00 |
| EN27540205 |  | CA54 SR5402 - KM drwgs |  | 19d | 2010-08-30 A | 2010-09-23 A | EN24540205, E3C170 FF, P3N01D, EN265402 | 100% | KM Drwgs preparation by Cheljabinsk [35 t] | EN27540205 | EN27540205 | 87B | N01H | 54 | N01H | 200 |  |  |  | Chel |  | E | N | EN27 | 5402 | de | LND | 0,00 |
| EN27540210 |  | CA54 SR5402 - Check KM drwgs |  | 10d | 2010-09-24 A | 2010-10-07 A | EN27540205 | 100% |  | EN27540210 | EN27540210 | 87B | N01H | 54 | N01H | 200 |  |  |  | LEI |  | E | N | EN27 | 5402 | de | LND |  |
| EN285402 |  | CA54 SR5402 - Shop dwgs(KMD) by Vendor |  | 51d | 2010-10-08 A | 2010-12-20 A | EN27540210 | 100% |  | EN285402 | EN285402 | 87B | N01H | 54 | N01H | 200 |  |  |  | Chel |  | E | N | EN28 | 5402 | de | LND |  |
| EN675402 |  | CA54 SR5402 - Grating Cut-Out drwgs |  | 26d | 2010-10-08 A | 2010-11-12 A | EN265402 FS+10d, ER425402 FF, F4460 FF+10d, EN27540210 | 100% | TKB-S [80 h] | EN675402 | EN675402 | 87B | N01H | 54 | N01H | 200 | 200 |  | C | LEI |  | E | N | EN67 | 5402 | de | LND | 80,00 |
| EN645402 |  | CA54 SR5402 - Check Grating Cut-Out drwgs |  | 7d | 2010-11-30 A | 2010-12-08 A | EN675402 FS+10d | 100% |  | EN645402 | EN645402 | 87B | N01H | 54 | N01H | 200 | 200 |  | C | LEI |  | E | N | EN67 | 5402 | de | LND |  |
| EN685402 |  | CA54 SR5402 - Grating Fabrication drwgs |  | 20d | 2010-12-09 A | 2011-01-07 A | EN675402, EN645402 | 100% |  | EN685402 | EN685402 | 87B | N01H | 54 | N01H | 200 | 200 |  | C | Chel |  | E | N | EN68 | 5402 | de | LND |  |
|  | R | **R Piping** |  |  | 2008-04-01 | 2011-01-31 |  |  |  |  |  |  |  |  |  |  |  |  |  |  |  |  |  |  |  |  |  |  |
| ER155402 |  | CA54 SR5402 - Conceptual Piping |  | 169d | 2008-04-01 A | 2008-11-28 A | ER155401 FF, F2760 | 100% |  | ER155402 | ER155402 | 876 |  | 54 |  | 200 |  |  |  | LND |  | E | R | ER15 | 5402 | PL | LND |  |
| ER305402 |  | CA54 SR5402 - CAD Model Piping / Equipment |  | 538d | 2008-06-02 A | 2010-07-23 A | ER155402 SS, ER395402 FF+10d, ER365402 FF+20d | 100% |  | ER305402 | ER305402 | 876 |  | 54 |  | 200 |  |  |  | LNI |  | E | R | ER30 | 5402 | PL | LND |  |
| ER165402 |  | CA54 SR5402 - prelim Loads for Struc Steel |  | 20d | 2009-01-05 A | 2009-01-30 A | ER155402 FF | 100% |  | ER165402 | ER165402 | 876 |  | 54 |  | 200 |  |  |  | LND |  | E | R | ER16 | 5402 | PL | LND |  |
| ER425402 |  | CA54 SR5402 - Stress Calculation / Final Loads |  | 98d | 2009-11-16 A | 2010-04-09 A | F4030 FF | 100% |  | ER425402 | ER425402 | 872 |  | 54 |  | 200 |  |  |  | LND |  | E | R | ER42 | 5402 | PL | LND |  |
| ER195402 |  | CA54 SR5402 - Final Loads for Struc Steel | milestone | 0d | 2010-01-04 A | 2010-01-04 A | EN21540210 SF-5d, F4030 FF+5d, ER165402 FF | 100% |  | ER195402 | ER195402 | 876 |  | 54 |  | 200 |  |  |  | LNI |  | E | R | ER19 | 5402 | PL | LND |  |
| ER365402 |  | CA54 SR5402 - CAD Model Review 60% |  | 15d | 2010-03-01 A | 2010-03-19 A | F4040 SS | 100% |  | ER365402 | ER365402 | 876 |  | 54 |  | 200 |  |  |  | LND |  | E | R | ER36 | 5402 | 2 | LND |  |
| ER395402 |  | CA54 SR5402 - CAD Model Review 90% |  | 10d | 2010-06-28 A | 2010-07-09 A | F4460 FF | 100% |  | ER395402 | ER395402 | 876 |  | 54 |  | 200 |  |  |  | LND |  | E | R | ER39 | 5402 | 3 | LND |  |
| ER455402 |  | CA54 SR5402 - Piping Isometrics |  | 69d | 2010-08-16 A | 2010-11-19 A | ER425402, ER305402 FF, ER395402 FS+25d | 100% |  | ER455402 | ER455402 | 876 |  | 54 |  | 200 |  |  |  | LEI |  | E | R | ER45 | 5402 | 5 | LND |  |
| ER475402 |  | CA54 SR5402 - Piping Layout drwgs |  | 87d | 2010-09-17 A | 2011-01-20 A | ER475101 FF+18d, ER305402, ER395402 FF+20d | 100% |  | ER475402 | ER475402 | 876 |  | 54 |  | 200 |  |  |  | LEI |  | E | R | ER47 | 5402 | 5 | LND |  |
| ER445402 |  | CA54 SR5402 - Piping Isometrics (UG) |  | 25d | 2010-10-04 A | 2010-11-05 A | ER440000 FF, EC305402 SS+20d | 100% |  | ER445402 | ER445402 | 876 |  | 54 |  | 200 | 200 |  | E | LND |  | E | R | ER44 | 5402 | 4 | LND |  |
| ER495402 |  | CA54 SR5402 - Design Check / Release Isos & BOM |  | 79d | 2010-10-08 A | 2011-01-31 A | ER455402 FF | 100% |  | ER495402 | ER495402 | 876 |  | 54 |  | 200 |  |  |  | LEI |  | E | R | ER49 | 5402 | 5 | LND |  |

| ID | WBS | Activity | Type | Duration | Start | Finish | Predecessors | Complete | Resources | UDF_SAVE ACTID | UDF_SAVE ACT ID | Department | Constr. Area | PMT-Phase | PMT-Respons. | WBS Phase | WBS Discipline | WBS Type of Work | WBS Objects | IMS | UPT | Pro Unit/DocCode | PMT-Area | TB26 Ressource Budget | Inquiry/Order No | Zeigen/n. Zeigen | Type of Work | PMT-Schedule Org | PMT-Discipline |
| --- | --- | --- | --- | --- | --- | --- | --- | --- | --- | --- | --- | --- | --- | --- | --- | --- | --- | --- | --- | --- | --- | --- | --- | --- | --- | --- | --- | --- | --- |
|  | E | **E Electrical** |  |  | 2008-10-06 | 2010-10-15 |  |  |  |  |  |  |  |  |  |  |  |  |  |  |  |  |  |  |  |  |  |  |  |
| EE46540205 |  | CA54 SR5402 - prelim Loads for Struc Steel |  | 10d | 2008-10-06 A | 2008-10-17 A | F3060 FF | 100% |  | EE46540205 | EE46540205 | 874 | 54 | E | LND | E | E | EE11 | 5402 | E | LND |  |  |  |  |  |  |  |  |
| EE905402 |  | CA54 SR5402 - Earthing Details |  | 30d | 2009-05-07 A | 2009-06-19 A | EE901201 SS, EE900070 | 100% |  | EE905402 | EE905402 | 874 | 54 | E | LND | E | E | EE90 | 5402 | E | LND |  |  |  |  |  |  |  |  |
| EE565402 |  | CA54 SR5402 - Cable Pulling Details |  | 164d | 2009-12-03 A | 2010-07-30 A | EE500130, EE46540210 FF | 100% |  | EE565402 | EE565402 | 874 | 54 | E | LEI | E | E | EE56 | 5402 | E | LND |  |  |  |  |  |  |  |  |
| EE46540210 |  | CA54 SR5402 - El. CableTray Layout Pl. 1st Issue |  | 197d | 2009-12-07 A | 2010-09-17 A | EE460000, F4030 FF+75d | 100% |  | EE46540210 | EE46540210 | 874 | 54 | E | LEI | E | E | EE46 | 5402 | E | LND |  |  |  |  |  |  |  |  |
| EE765402 |  | CA54 SR5402 - Layout Plan Light.& Sockets 1st Issue |  | 185d | 2010-01-26 A | 2010-10-15 A | EE000180 FS+10d | 100% |  | EE765402 | EE765402 | 874 | 54 | E | LEI | E | E | EE76 | 5402 | E | LND |  |  |  |  |  |  |  |  |
| EE46540208 |  | CA54 SR5402 - Final Loads for Struc Steel |  | 37d | 2010-02-22 A | 2010-04-15 A | EE46540205 | 100% |  | EE46540208 | EE46540208 | 874 | 54 | E | LEI | E | E | EE12 | 5402 | E | LND |  |  |  |  |  |  |  |  |
|  | J | **J Instrumentation** |  |  | 2008-10-06 | 2010-09-17 |  |  |  |  |  |  |  |  |  |  |  |  |  |  |  |  |  |  |  |  |  |  |  |
| EJ46540205 |  | CA54 SR5402 - prelim Loads for Struc Steel |  | 15d | 2008-10-06 A | 2008-10-24 A | F3060 FF | 100% |  | EJ46540205 | EJ46540205 | 86E | 54 | E | LND | E | J | EJ11 | 5402 | I | LND | 999 |  |  |  |  |  |  |  |
| EJ46540210 |  | CA54 SR5402 - Instr Cable Tray Layout Plans 1st Issue |  | 141d | 2010-03-01 A | 2010-09-17 A | EE46540210 FF, F4030 FF, F4460 | 100% |  | EJ46540210 | EJ46540210 | 86E | 54 | E | LEI | E | J | EJ41 | 5402 | I | LND | 999 |  |  |  |  |  |  |  |
| EJ46540208 |  | CA54 SR5402 - Final Loads for Struc Steel |  | 10d | 2010-03-31 A | 2010-04-15 A | EJ46540205 | 100% |  | EJ46540208 | EJ46540208 | 86E | 54 | E | LEI | E | J | EJ12 | 5402 | I | LND | 999 |  |  |  |  |  |  |  |
|  | 55 | **55 CA55 - Piperack (between CA16/17/56)** |  |  | 2008-03-03 | 2011-10-18 |  |  |  |  |  |  |  |  |  |  |  |  |  |  |  |  |  |  |  |  |  |  |  |
|  | 5501 | **5501 Pipe Rack 5 - Part 1 - CA55** |  |  | 2008-03-03 | 2011-01-31 |  |  |  |  |  |  |  |  |  |  |  |  |  |  |  |  |  |  |  |  |  |  |  |
|  | C | **C Civil** |  |  | 2010-03-01 | 2010-09-20 |  |  |  |  |  |  |  |  |  |  |  |  |  |  |  |  |  |  |  |  |  |  |  |
| EC225501 |  | CA55 SR5501 - Layout Drwg / Loads IFD |  | 10d | 2010-03-01 A | 2010-03-12 A | EN255501 | 100% |  | EC225501 | EC225501 | 87A | 55 |  | LND | E | C | EC22 | 5501 | de | LND | 5500C01 | 200 |  |  |  |  |  |  |
| EC155501 |  | CA55 SR5501 - Piling drwgs AFC |  | 39d | 2010-03-15 A | 2010-05-10 A | EC265501 SS | 100% |  | EC155501 | EC155501 | 87A | 55 |  | IPR | E | C | EC15 | 5501 | PI | LND | 5501C16 | 200 |  |  |  |  |  |  |
| EC265501 |  | CA55 SR5501 - Civil Static Calc Fdtn |  | 132d | 2010-03-15 A | 2010-09-20 A | EC225501, EC461710 SS+30d, P3C0BD FS+10d, EC265402 SS | 100% |  | EC265501 | EC265501 | 87A | 55 |  | IPR | E | C | EC26 | 5501 | de | LND | 5501C14 | 200 |  |  |  |  |  |  |
| EC45550105 |  | CA55 SR5501 - Civil Layout drwgs AFC |  | 94d | 2010-03-15 A | 2010-07-28 A | P3C0BD FS+10d, EC225501, AD2230, EC265501 SS | 100% |  | EC45550105 | EC45550105 | 87A | 55 | E | IPR | E | C | EC45 | 5501 | ar | LND | 5501C13 | 200 |  |  |  |  |  |  |
| EC285501 |  | CA55 SR5501 - Formw/Reinforce drwgs AFC |  | 80d | 2010-03-30 A | 2010-07-23 A | EC265501 SS+10d, EC155501 SS+15d | 100% |  | EC285501 | EC285501 | 87A | 55 |  | IPR | E | C | EC28 | 5501 | cq | LND | 5501C21 | 200 |  |  |  |  |  |  |
| EC075505 |  | CA55 SR5500 - Issue of working drwgs (AFC) by RDI |  | 96d | 2010-04-14 A | 2010-08-27 A | EC285501 FF, EC45550105 FF, EC285502 FF, EC285503 FF | 100% | TKB-B [640 h] | EC075505 | EC075505 | 87A | 55 | E | IPR | E | C | EC07 | 5501 | cq | LND | 1010C13 | 200 | 640,00 | 999 | FL |  |  |  |
| EC075500 |  | CA55 SR5500 - Check & Release of working drwgs (AFC) |  | 91d | 2010-04-21 A | 2010-08-27 A | EC285503 FF+5d, EC285502 FF+5d, EC45550105 SS+25d, EC285501 FF+5d, EC075505 FF+5d | 100% | TKB-B [88 h] | EC075500 | EC075500 | 87A | 55 | E | LND | E | C | EC07 | 5501 | cq | LND |  | 200 | 88,00 | 999 | FL |  |  |  |
|  | N | **N Structural Steel** |  |  | 2008-03-03 | 2010-12-06 |  |  |  |  |  |  |  |  |  |  |  |  |  |  |  |  |  |  |  |  |  |  |  |
| EN155501 |  | CA55 SR5501 - CAD Model/Concepts StrSteel |  | 126d | 2008-03-03 A | 2008-08-29 A | EN155402 FF | 100% |  | EN155501 | EN155501 | 87B | 55 | E | LND | E | N | EN15 | 5501 | de | LND |  | 200 |  | N01I | 0 | N01I | 200 | 055 |
| EN21550105 |  | CA55 SR5501 - GA-Drwgs + Fdtn Loads |  | 15d | 2009-03-02 A | 2009-03-20 A | EN155501 FF, EE46550105, EJ46550105, AD2230 FS+45d, ER165501 | 100% |  | EN21550105 | EN21550105 | 87B | 55 |  | LND | E | N | EN21 | 5501 | de | LND |  | 200 |  | N01I |  | N01I |  |  |
| EN24550105 |  | CA55 SR5501 - Static Calc for Fdtn Loads |  | 20d | 2009-11-09 A | 2009-12-07 A | EN21550105 FS+10d | 100% |  | EN24550105 | EN24550105 | 87B | 55 |  | LND | E | N | EN24 | 5501 | de | LND |  | 200 |  | N01I |  | N01I |  |  |
| EN255501 |  | CA55 SR5501 - Loads for Civil | milestone | 0d | 2009-12-07 A | 2009-12-07 A | EN24550105 FF | 100% |  | EN255501 | EN255501 | 87B | 55 | E | LND | E | N | EN25 | 5501 | de | LND |  | 200 |  | N01I | 0 | N01I | 200 | 055 |
| EN21550110 |  | CA55 SR5501 - GA-Drwgs + Final Loads |  | 67d | 2009-12-08 A | 2010-03-16 A | ER425501, EN21550105 FS+15d, EN24550105, EJ46550108 FF, EE46550108 | 100% | TKB-S [128 h] | EN21550110 | EN21550110 | 87B | 55 |  | LND | E | N | EN21 | 5501 | de | LND |  | 200 | 128,00 | N01I |  | N01I |  |  |
| EN24550110 |  | CA55 SR5501 - Final Static Calc |  | 116d | 2009-12-28 A | 2010-06-15 A | EN21550110, ER195501 FF | 100% | TKB-S [240 h] | EN24550110 | EN24550110 | 87B | 55 |  | LND | E | N | EN24 | 5501 | de | LND |  | 200 | 240,00 | N01I |  | N01I |  |  |
| EN265501 |  | CA55 SR5501 - Layout dwgs input for KM dwgs |  | 42d | 2010-04-27 A | 2010-06-25 A | F4030 FF+20d, EN24550110 FF+8d | 100% | TKB-S [160 h] | EN265501 | EN265501 | 87B | 55 |  | LND | E | N | EN26 | 5501 | st | LND |  | 200 | 160,00 | N01I |  | N01I |  |  |
| EN675501 |  | CA55 SR5501 - Grating Cut-Out drwgs |  | 28d | 2010-05-28 A | 2010-07-06 A | ER425501 FF | 100% | TKB-S [80 h] | EN675501 | EN675501 | 87B | 55 | C | LND | E | N | EN67 | 5501 | de | LND |  | 200 | 80,00 | N01I |  | N01I | 200 |  |
| EN27550105 |  | CA55 SR5501 - KM drwgs |  | 23d | 2010-07-07 A | 2010-08-06 A | EN24550105, EN265501 | 100% | KM Drwgs preparation by Cheljabinsk [35 t] | EN27550105 | EN27550105 | 87B | 55 |  | Chel | E | N | EN27 | 5501 | de | LND |  | 200 | 0,00 | N01I |  | N01I |  |  |
| EN645501 |  | CA55 SR5501 - Check Grating Cut-Out drwgs |  | 2d | 2010-07-07 A | 2010-07-08 A | EN675501 | 100% |  | EN645501 | EN645501 | 87B | 55 | C | LEI | E | N | EN67 | 5501 | de | LND |  | 200 |  | N01I |  | N01I | 200 |  |
| EN685501 |  | CA55 SR5501 - Grating Fabrication drwgs |  | 20d | 2010-07-09 A | 2010-08-05 A | EN675501, EN645501 | 100% |  | EN685501 | EN685501 | 87B | 55 | C | Chel | E | N | EN68 | 5501 | de | LND |  | 200 |  | N01I |  | N01I | 200 |  |
| EN27550110 |  | CA55 SR5501 - Check KM drwgs |  | 37d | 2010-08-09 A | 2010-09-28 A | EN27550105 | 100% |  | EN27550110 | EN27550110 | 87B | 55 |  | LND | E | N | EN27 | 5501 | de | LND |  | 200 |  | N01I |  | N01I |  |  |
| EN285501 |  | CA55 SR5501 - Shop dwgs(KMD) by Vendor |  | 48d | 2010-09-29 A | 2010-12-06 A | EN27550110 | 100% |  | EN285501 | EN285501 | 87B | 55 |  | Chel | E | N | EN28 | 5501 | de | LND |  | 200 |  | N01I |  | N01I |  |  |

Notes:
- EC225501: P3 Activity Log Info: TKB-B Keyplan to Subcontractor
- EC45550105: P3 Activity Log Info: incl. PMT approval

| ID | WBS | Activity | Type | Duration | Start | Finish | Predecessors | Complete | UDF_SAVE ACTID | UDF_SAVE ACT ID | Department | Constr. Area | PMT-Area | PMT-Respons. | WBS Phase | WBS Discipline | WBS Type of Work | WBS Objects | IMS | UPT | PMT-Schedule Org | PMT-Phase | Pro Unit/DocCode |
| --- | --- | --- | --- | --- | --- | --- | --- | --- | --- | --- | --- | --- | --- | --- | --- | --- | --- | --- | --- | --- | --- | --- | --- |
|  | R | **R Piping** |  |  | 2008-04-01 | 2011-01-31 |  |  |  |  |  |  |  |  |  |  |  |  |  |  |  |  |  |
| ER155501 |  | CA55 SR5501 - Conceptual Piping |  | 169d | 2008-04-01 A | 2008-11-28 A | ER155402 FF, F2760 | 100% | ER155501 | ER155501 | 876 | 55 | 200 | LND | E | R | ER15 | 5501 | PL | LND |  |  |  |
| ER305501 |  | CA55 SR5501 - CAD Model Piping / Equipment |  | 538d | 2008-06-02 A | 2010-07-23 A | ER365501 FF+20d, ER395501 FF+10d, ER155501 SS | 100% | ER305501 | ER305501 | 876 | 55 | 200 | LNI | E | R | ER30 | 5501 | PL | LND |  |  |  |
| ER165501 |  | CA55 SR5501 - prelim Loads for Struc Steel |  | 20d | 2009-01-05 A | 2009-01-30 A | ER155501 FF | 100% | ER165501 | ER165501 | 876 | 55 | 200 | LND | E | R | ER16 | 5501 | PL | LND |  |  |  |
| ER365501 |  | CA55 SR5501 - CAD Model Review 60% |  | 12d | 2009-11-02 A | 2009-11-17 A | F4030 SS | 100% | ER365501 | ER365501 | 876 | 55 | 200 | LND | E | R | ER36 | 5501 | 2 | LND |  |  |  |
| ER425501 |  | CA55 SR5501 - Stress Calculation / Final Loads |  | 98d | 2009-11-16 A | 2010-04-09 A | F4030 FF | 100% | ER425501 | ER425501 | 872 | 55 | 200 | LND | E | R | ER42 | 5501 | PL | LND |  |  |  |
| ER195501 |  | CA55 SR5501 - Final Loads for Struc Steel | milestone | 0d | 2009-12-01 A | 2009-12-01 A | ER165501 FF, EN21550110 FF-5d, F4030 FF+5d | 100% | ER195501 | ER195501 | 876 | 55 | 200 | LNI | E | R | ER19 | 5501 | PL | LND |  |  |  |
| ER395501 |  | CA55 SR5501 - CAD Model Review 90% |  | 10d | 2010-06-28 A | 2010-07-09 A | F4460 FF | 100% | ER395501 | ER395501 | 876 | 55 | 200 | LND | E | R | ER39 | 5501 | 3 | LND |  |  |  |
| ER455501 |  | CA55 SR5501 - Piping Isometrics |  | 64d | 2010-08-23 A | 2010-11-19 A | ER305501 FF+5d, ER425501, ER395501 FS+30d | 100% | ER455501 | ER455501 | 876 | 55 | 200 | LEI | E | R | ER45 | 5501 | 5 | LND |  |  |  |
| ER475501 |  | CA55 SR5501 - Piping Layout drwgs |  | 87d | 2010-09-17 A | 2011-01-20 A | ER475101 FF+18d, ER305501, ER395501 FF+20d | 100% | ER475501 | ER475501 | 876 | 55 | 200 | LEI | E | R | ER47 | 5501 | 5 | LND |  |  |  |
| ER445501 |  | CA55 SR5501 - Piping Isometrics (UG) |  | 25d | 2010-10-04 A | 2010-11-05 A | EC305501 SS+20d, ER440000 FF, IMS-E-000100 FF | 100% | ER445501 | ER445501 | 876 | 55 | 200 | LND | E | R | ER44 | 5501 | 4 | LND | 200 | E |  |
| ER495501 |  | CA55 SR5501 - Design Check / Release Isos & BOM |  | 79d | 2010-10-08 A | 2011-01-31 A | ER455501 FF | 100% | ER495501 | ER495501 | 876 | 55 | 200 | LEI | E | R | ER49 | 5501 | 5 | LND |  |  |  |
|  | E | **E Electrical** |  |  | 2008-10-06 | 2010-10-29 |  |  |  |  |  |  |  |  |  |  |  |  |  |  |  |  |  |
| EE46550105 |  | CA55 SR5501 - prelim Loads for Struc Steel |  | 10d | 2008-10-06 A | 2008-10-17 A | F3060 FF | 100% | EE46550105 | EE46550105 | 874 | 55 |  | LND | E | E | EE11 | 5501 | E | LND |  | E |  |
| EE905501 |  | CA55 SR5501 - Earthing Details |  | 30d | 2009-05-07 A | 2009-06-19 A | EE901201 SS, EE900070 | 100% | EE905501 | EE905501 | 874 | 55 |  | LND | E | E | EE90 | 5501 | E | LND |  | E |  |
| EE46550108 |  | CA55 SR5501 - Final Loads for Struc Steel |  | 20d | 2009-11-09 A | 2009-12-07 A | EE46550105 | 100% | EE46550108 | EE46550108 | 874 | 55 |  | LEI | E | E | EE12 | 5501 | E | LND |  | E |  |
| EE565501 |  | CA55 SR5501 - Cable Pulling Details |  | 164d | 2009-12-03 A | 2010-07-30 A | EE46550110 FF, EE500130 | 100% | EE565501 | EE565501 | 874 | 55 |  | LEI | E | E | EE56 | 5501 | E | LND |  | E |  |
| EE46550110 |  | CA55 SR5501 - El. CableTray Layout Pl. 1st Issue |  | 197d | 2009-12-07 A | 2010-09-17 A | F4030 FF+75d, EE460000 | 100% | EE46550110 | EE46550110 | 874 | 55 |  | LEI | E | E | EE46 | 5501 | E | LND |  | E |  |
| EE765501 |  | CA55 SR5501 - Layout Plan Light.& Sockets 1st Issue |  | 195d | 2010-01-26 A | 2010-10-29 A | EE000180 FS+10d | 100% | EE765501 | EE765501 | 874 | 55 |  | LEI | E | E | EE76 | 5501 | E | LND |  | E |  |
|  | J | **J Instrumentation** |  |  | 2008-10-06 | 2010-09-17 |  |  |  |  |  |  |  |  |  |  |  |  |  |  |  |  |  |
| EJ46550105 |  | CA55 SR5501 - prelim Loads for Struc Steel |  | 15d | 2008-10-06 A | 2008-10-24 A | F3060 FF | 100% | EJ46550105 | EJ46550105 | 86E | 55 |  | LND | E | J | EJ11 | 5501 | I | LND |  | E | 999 |
| EJ46550108 |  | CA55 SR5501 - Final Loads for Struc Steel |  | 10d | 2009-12-15 A | 2009-12-30 A | EJ46550105 | 100% | EJ46550108 | EJ46550108 | 86E | 55 |  | LEI | E | J | EJ12 | 5501 | I | LND |  | E | 999 |
| EJ46550110 |  | CA55 SR5501 - Instr Cable Tray Layout Plans 1st Issue |  | 141d | 2010-03-01 A | 2010-09-17 A | EE46550110 FF, F4460, F4030 FF | 100% | EJ46550110 | EJ46550110 | 86E | 55 |  | LEI | E | J | EJ41 | 5501 | I | LND |  | E | 999 |
|  | 5502 | **5502 Pipe Rack 5 - Part 2 - CA55** |  |  | 2008-03-03 | 2011-01-31 |  |  |  |  |  |  |  |  |  |  |  |  |  |  |  |  |  |
|  | C | **C Civil** |  |  | 2010-03-01 | 2010-09-20 |  |  |  |  |  |  |  |  |  |  |  |  |  |  |  |  |  |
| EC225502 |  | CA55 SR5502 - Layout Drwg / Loads IFD |  | 10d | 2010-03-01 A | 2010-03-12 A | EN255502 | 100% | EC225502 | EC225502 | 87A | 55 | 200 | LND | E | C | EC22 | 5502 | de | LND | 200 | E |  |
| EC155502 |  | CA55 SR5502 - Piling drwgs AFC |  | 39d | 2010-03-15 A | 2010-05-10 A | EC265502 SS | 100% | EC155502 | EC155502 | 87A | 55 | 200 | IPR | E | C | EC15 | 5502 | PI | LND |  |  | 5502C16 |
| EC265502 |  | CA55 SR5502 - Civil Static Calc Fdtn |  | 132d | 2010-03-15 A | 2010-09-20 A | EC225502, EC265501 SS, P3C0BD FS+10d | 100% | EC265502 | EC265502 | 87A | 55 | 200 | IPR | E | C | EC26 | 5502 | de | LND | 200 | E | 5502C14 |
| EC45550205 |  | CA55 SR5502 - Civil Layout drwgs AFC |  | 94d | 2010-03-15 A | 2010-07-28 A | AD2230, P3C0BD FS+10d, EC265502 SS, EC225502 | 100% | EC45550205 | EC45550205 | 87A | 55 | 200 | IPR | E | C | EC45 | 5502 | ar | LND |  | E | 5502C13 |
| EC285502 |  | CA55 SR5502 - Formw/Reinforce drwgs AFC |  | 80d | 2010-03-30 A | 2010-07-23 A | EC265502 SS+10d, EC155502 SS+15d | 100% | EC285502 | EC285502 | 87A | 55 | 200 | IPR | E | C | EC28 | 5502 | cq | LND | 200 | E | 5502C21 |

Notes:
- EC225502: P3 Activity Log Info: TKB-B Keyplan to Subcontractor
- EC45550205: P3 Activity Log Info: incl. PMT approval

| ID | WBS | Activity | Type | Duration | Start | Finish | Predecessors | Complete | Resources | UDF_SAVE ACTID | UDF_SAVE ACT ID | Department | Type of Work | Constr. Area | Inquiry/Order No | PMT-Area | PMT-Schedule Org | PMT-Discipline | PMT-Phase | PMT-Respons. | Zeigen/n. Zeigen | WBS Phase | WBS Discipline | WBS Type of Work | WBS Objects | IMS | UPT | TB26 Ressource Budget |
| --- | --- | --- | --- | --- | --- | --- | --- | --- | --- | --- | --- | --- | --- | --- | --- | --- | --- | --- | --- | --- | --- | --- | --- | --- | --- | --- | --- | --- |
|  | N | **N Structural Steel** |  |  | 2008-03-03 | 2010-11-29 |  |  |  |  |  |  |  |  |  |  |  |  |  |  |  |  |  |  |  |  |  |  |
| EN155502 |  | CA55 SR5502 - CAD Model/Concepts StrSteel |  | 126d | 2008-03-03 A | 2008-08-29 A | EN155501 FF | 100% |  | EN155502 | EN155502 | 87B | N01L | 55 | N01L | 200 | 200 | 055 | E | LND | 0 | E | N | EN15 | 5502 | de | LND |  |
| EN21550205 |  | CA55 SR5502 - GA-Drwgs + Fdtn Loads |  | 15d | 2009-03-16 A | 2009-04-03 A | AD2230 FS+55d, EE46550205, EN155502, ER165502, EN155503, EJ46550205 | 100% |  | EN21550205 | EN21550205 | 87B | N01L | 55 | N01L | 200 |  |  |  | LND |  | E | N | EN21 | 5502 | de | LND |  |
| EN24550205 |  | CA55 SR5502 - Static Calc for Fdtn Loads |  | 20d | 2009-11-09 A | 2009-12-07 A | EN21550205 | 100% |  | EN24550205 | EN24550205 | 87B | N01L | 55 | N01L | 200 |  |  |  | LND |  | E | N | EN24 | 5502 | de | LND |  |
| EN255502 |  | CA55 SR5502 - Loads for Civil | milestone | 0d | 2009-12-07 A | 2009-12-07 A | EN24550205 FF | 100% |  | EN255502 | EN255502 | 87B | N01L | 55 | N01L | 200 | 200 | 055 | E | LND | 0 | E | N | EN25 | 5502 | de | LND |  |
| EN21550210 |  | CA55 SR5502 - GA-Drwgs + Final Loads |  | 70d | 2009-12-08 A | 2010-03-19 A | EE46550208, EN21550205 FS+10d, ER425502, EJ46550208 FF, EN24550205 | 100% | TKB-S [192 h] | EN21550210 | EN21550210 | 87B | N01L | 55 | N01L | 200 |  |  |  | LND |  | E | N | EN21 | 5502 | de | LND | 192,00 |
| EN24550210 |  | CA55 SR5502 - Final Static Calc |  | 121d | 2009-12-28 A | 2010-06-22 A | ER195502 FF, EN21550210 | 100% | TKB-S [240 h] | EN24550210 | EN24550210 | 87B | N01L | 55 | N01L | 200 |  |  |  | LND |  | E | N | EN24 | 5502 | de | LND | 240,00 |
| EN265502 |  | CA55 SR5502 - Layout dwgs input for KM dwgs |  | 44d | 2010-04-27 A | 2010-06-29 A | EN24550210 FF+5d, F4030 FF+20d | 100% | TKB-S [240 h] | EN265502 | EN265502 | 87B | N01L | 55 | N01L | 200 |  |  |  | LND |  | E | N | EN26 | 5502 | st | LND | 240,00 |
| EN675502 |  | CA55 SR5502 - Grating Cut-Out drwgs |  | 28d | 2010-05-28 A | 2010-07-06 A | ER425502 FF | 100% | TKB-S [80 h] | EN675502 | EN675502 | 87B | N01L | 55 | N01L | 200 | 200 |  | C | LND |  | E | N | EN67 | 5502 | de | LND | 80,00 |
| EN27550205 |  | CA55 SR5502 - KM drwgs |  | 35d | 2010-07-07 A | 2010-08-24 A | EN24550205, EN265502 | 100% | KM Drwgs preparation by Cheljabinsk [80 t] | EN27550205 | EN27550205 | 87B | N01L | 55 | N01L | 200 |  |  |  | Chel |  | E | N | EN27 | 5502 | de | LND | 0,00 |
| EN645502 |  | CA55 SR5502 - Check Grating Cut-Out drwgs |  | 2d | 2010-07-07 A | 2010-07-08 A | EN675502 | 100% |  | EN645502 | EN645502 | 87B | N01L | 55 | N01L | 200 | 200 |  | C | LEI |  | E | N | EN67 | 5502 | de | LND |  |
| EN685502 |  | CA55 SR5502 - Grating Fabrication drwgs |  | 20d | 2010-07-09 A | 2010-08-05 A | EN675502, EN645502 | 100% |  | EN685502 | EN685502 | 87B | N01L | 55 | N01L | 200 | 200 |  | C | Chel |  | E | N | EN68 | 5502 | de | LND |  |
| EN27550210 |  | CA55 SR5502 - Check KM drwgs |  | 24d | 2010-08-26 A | 2010-09-28 A | EN27550205 | 100% |  | EN27550210 | EN27550210 | 87B | N01L | 55 | N01L | 200 |  |  |  | LND |  | E | N | EN27 | 5502 | de | LND |  |
| EN285502 |  | CA55 SR5502 - Shop dwgs(KMD) by Vendor |  | 43d | 2010-09-29 A | 2010-11-29 A | EN27550210 | 100% |  | EN285502 | EN285502 | 87B | N01L | 55 | N01L | 200 |  |  |  | Chel |  | E | N | EN28 | 5502 | de | LND |  |
|  | R | **R Piping** |  |  | 2008-04-01 | 2011-01-31 |  |  |  |  |  |  |  |  |  |  |  |  |  |  |  |  |  |  |  |  |  |  |
| ER155502 |  | CA55 SR5502 - Conceptual Piping |  | 169d | 2008-04-01 A | 2008-11-28 A | ER155402 FF | 100% |  | ER155502 | ER155502 | 876 |  | 55 |  | 200 |  |  |  | LND |  | E | R | ER15 | 5502 | PL | LND |  |
| ER305502 |  | CA55 SR5502 - CAD Model Piping / Equipment |  | 538d | 2008-06-02 A | 2010-07-23 A | ER395502 FF+10d, ER155502 SS, ER365502 FF+20d | 100% |  | ER305502 | ER305502 | 876 |  | 55 |  | 200 |  |  |  | LNI |  | E | R | ER30 | 5502 | PL | LND |  |
| ER165502 |  | CA55 SR5502 - prelim Loads for Struc Steel |  | 20d | 2009-01-05 A | 2009-01-30 A | ER155502 FF | 100% |  | ER165502 | ER165502 | 876 |  | 55 |  | 200 |  |  |  | LND |  | E | R | ER16 | 5502 | PL | LND |  |
| ER365502 |  | CA55 SR5502 - CAD Model Review 60% |  | 12d | 2009-11-02 A | 2009-11-17 A | F4030 SS | 100% |  | ER365502 | ER365502 | 876 |  | 55 |  | 200 |  |  |  | LND |  | E | R | ER36 | 5502 | 2 | LND |  |
| ER425502 |  | CA55 SR5502 - Stress Calculation / Final Loads |  | 98d | 2009-11-16 A | 2010-04-09 A | F4030 FF | 100% |  | ER425502 | ER425502 | 872 |  | 55 |  | 200 |  |  |  | LND |  | E | R | ER42 | 5502 | PL | LND |  |
| ER195502 |  | CA55 SR5502 - Final Loads for Struc Steel | milestone | 0d | 2009-11-25 A | 2009-11-25 A | EN21550210 FF-10d, ER165502 FF, F4030 FF+5d | 100% |  | ER195502 | ER195502 | 876 |  | 55 |  | 200 |  |  |  | LNI |  | E | R | ER19 | 5502 | PL | LND |  |
| ER395502 |  | CA55 SR5502 - CAD Model Review 90% |  | 10d | 2010-06-28 A | 2010-07-09 A | F4460 FF | 100% |  | ER395502 | ER395502 | 876 |  | 55 |  | 200 |  |  |  | LND |  | E | R | ER39 | 5502 | 3 | LND |  |
| ER455502 |  | CA55 SR5502 - Piping Isometrics |  | 64d | 2010-08-23 A | 2010-11-19 A | ER425502, ER305502 FF, ER395502 FS+30d | 100% |  | ER455502 | ER455502 | 876 |  | 55 |  | 200 |  |  |  | LEI |  | E | R | ER45 | 5502 | 5 | LND |  |
| ER475502 |  | CA55 SR5502 - Piping Layout drwgs |  | 87d | 2010-09-17 A | 2011-01-20 A | ER395502 FF+20d, ER475101 FF+18d, ER305502 | 100% |  | ER475502 | ER475502 | 876 |  | 55 |  | 200 |  |  |  | LEI |  | E | R | ER47 | 5502 | 5 | LND |  |
| ER445502 |  | CA55 SR5502 - Piping Isometrics (UG) |  | 25d | 2010-10-04 A | 2010-11-05 A | ER440000 FF, EC305502 SS+20d | 100% |  | ER445502 | ER445502 | 876 |  | 55 |  | 200 | 200 |  | E | LND |  | E | R | ER44 | 5502 | 4 | LND |  |
| ER495502 |  | CA55 SR5502 - Design Check / Release Isos & BOM |  | 79d | 2010-10-08 A | 2011-01-31 A | ER455502 FF | 100% |  | ER495502 | ER495502 | 876 |  | 55 |  | 200 |  |  |  | LEI |  | E | R | ER49 | 5502 | 5 | LND |  |

| ID | WBS | Activity | Type | Duration | Start | Finish | Predecessors | Complete | UDF_SAVE ACTID | UDF_SAVE ACT ID | Department | Constr. Area | PMT-Phase | PMT-Respons. | WBS Phase | WBS Discipline | WBS Type of Work | WBS Objects | IMS | UPT | Pro Unit/DocCode | PMT-Area | PMT-Schedule Org |
| --- | --- | --- | --- | --- | --- | --- | --- | --- | --- | --- | --- | --- | --- | --- | --- | --- | --- | --- | --- | --- | --- | --- | --- |
|  | E | **E Electrical** |  |  | 2008-10-06 | 2010-10-29 |  |  |  |  |  |  |  |  |  |  |  |  |  |  |  |  |  |
| EE46550205 |  | CA55 SR5502 - prelim Loads for Struc Steel |  | 10d | 2008-10-06 A | 2008-10-17 A | F3060 FF | 100% | EE46550205 | EE46550205 | 874 | 55 | E | LND | E | E | EE11 | 5502 | E | LND |  |  |  |
| EE905502 |  | CA55 SR5502 - Earthing Details |  | 30d | 2009-05-07 A | 2009-06-19 A | EE901201 SS, EE900070 | 100% | EE905502 | EE905502 | 874 | 55 | E | LND | E | E | EE90 | 5502 | E | LND |  |  |  |
| EE46550208 |  | CA55 SR5502 - Final Loads for Struc Steel |  | 20d | 2009-11-09 A | 2009-12-07 A | EE46550205 | 100% | EE46550208 | EE46550208 | 874 | 55 | E | LEI | E | E | EE12 | 5502 | E | LND |  |  |  |
| EE565502 |  | CA55 SR5502 - Cable Pulling Details |  | 164d | 2009-12-03 A | 2010-07-30 A | EE46550210 FF, EE500130 | 100% | EE565502 | EE565502 | 874 | 55 | E | LEI | E | E | EE56 | 5502 | E | LND |  |  |  |
| EE46550210 |  | CA55 SR5502 - El. CableTray Layout Pl. 1st Issue |  | 197d | 2009-12-07 A | 2010-09-17 A | EE460000, F4030 FF+75d | 100% | EE46550210 | EE46550210 | 874 | 55 | E | LEI | E | E | EE46 | 5502 | E | LND |  |  |  |
| EE765502 |  | CA55 SR5502 - Layout Plan Light.& Sockets 1st Issue |  | 195d | 2010-01-26 A | 2010-10-29 A | EE000180 FS+10d | 100% | EE765502 | EE765502 | 874 | 55 | E | LEI | E | E | EE76 | 5502 | E | LND |  |  |  |
|  | J | **J Instrumentation** |  |  | 2008-10-06 | 2010-09-17 |  |  |  |  |  |  |  |  |  |  |  |  |  |  |  |  |  |
| EJ46550205 |  | CA55 SR5502 - prelim Loads for Struc Steel |  | 15d | 2008-10-06 A | 2008-10-24 A | F3060 FF | 100% | EJ46550205 | EJ46550205 | 86E | 55 | E | LND | E | J | EJ11 | 5502 | I | LND | 999 |  |  |
| EJ46550208 |  | CA55 SR5502 - Final Loads for Struc Steel |  | 10d | 2009-12-15 A | 2009-12-30 A | EJ46550205 | 100% | EJ46550208 | EJ46550208 | 86E | 55 | E | LEI | E | J | EJ12 | 5502 | I | LND | 999 |  |  |
| EJ46550210 |  | CA55 SR5502 - Instr Cable Tray Layout Plans 1st Issue |  | 141d | 2010-03-01 A | 2010-09-17 A | EE46550210 FF, F4460, F4030 FF | 100% | EJ46550210 | EJ46550210 | 86E | 55 | E | LEI | E | J | EJ41 | 5502 | I | LND | 999 |  |  |
|  | 5503 | **5503 Pipe Rack 5 - Part 3 - CA55** |  |  | 2008-04-01 | 2011-10-18 |  |  |  |  |  |  |  |  |  |  |  |  |  |  |  |  |  |
|  | C | **C Civil** |  |  | 2010-03-01 | 2010-09-20 |  |  |  |  |  |  |  |  |  |  |  |  |  |  |  |  |  |
| EC225503 |  | CA55 SR5503 - Layout Drwg / Loads IFD |  | 10d | 2010-03-01 A | 2010-03-12 A | EC440000 FF, EN255503 | 100% | EC225503 | EC225503 | 87A | 55 | E | LND | E | C | EC22 | 5503 | de | LND |  | 200 | 200 |
| EC155503 |  | CA55 SR5503 - Piling drwgs AFC |  | 39d | 2010-03-15 A | 2010-05-10 A | EC155502 SS, EC265503 SS | 100% | EC155503 | EC155503 | 87A | 55 |  | IPR | E | C | EC15 | 5503 | PI | LND | 5503C16 | 200 |  |
| EC265503 |  | CA55 SR5503 - Civil Static Calc Fdtn |  | 132d | 2010-03-15 A | 2010-09-20 A | P3C0BD FS+10d, EC265502 SS, EC225503 | 100% | EC265503 | EC265503 | 87A | 55 | E | IPR | E | C | EC26 | 5503 | de | LND | 5503C14 | 200 | 200 |
| EC45550305 |  | CA55 SR5503 - Civil Layout drwgs AFC |  | 94d | 2010-03-15 A | 2010-07-28 A | EC265503 SS, AD2230, EC225503, P3C0BD FS+10d | 100% | EC45550305 | EC45550305 | 87A | 55 | E | IPR | E | C | EC45 | 5503 | ar | LND | 5503C13 | 200 |  |
| EC285503 |  | CA55 SR5503 - Formw/Reinforce drwgs AFC |  | 80d | 2010-03-30 A | 2010-07-23 A | EC265503 SS+10d, EC155503 SS+15d | 100% | EC285503 | EC285503 | 87A | 55 | E | IPR | E | C | EC28 | 5503 | cq | LND | 5503C21 | 200 | 200 |
|  | N | **N Structural Steel** |  |  |  |  |  |  |  |  |  |  |  |  |  |  |  |  |  |  |  |  |  |
|  | R | **R Piping** |  |  | 2008-04-01 | 2011-01-31 |  |  |  |  |  |  |  |  |  |  |  |  |  |  |  |  |  |
| ER155503 |  | CA55 SR5503 - Conceptual Piping |  | 169d | 2008-04-01 A | 2008-11-28 A | F2760 | 100% | ER155503 | ER155503 | 876 | 55 |  | LND | E | R | ER15 | 5503 | PL | LND |  | 200 |  |
| ER305503 |  | CA55 SR5503 - CAD Model Piping / Equipment |  | 538d | 2008-06-02 A | 2010-07-23 A | ER365503 FF+20d, ER395503 FF+10d, ER155503 SS | 100% | ER305503 | ER305503 | 876 | 55 |  | LNI | E | R | ER30 | 5503 | PL | LND |  | 200 |  |
| ER165503 |  | CA55 SR5503 - prelim Loads for Struc Steel |  | 20d | 2009-01-05 A | 2009-01-30 A | ER155503 FF | 100% | ER165503 | ER165503 | 876 | 55 |  | LND | E | R | ER16 | 5503 | PL | LND |  | 200 |  |
| ER365503 |  | CA55 SR5503 - CAD Model Review 60% |  | 12d | 2009-11-02 A | 2009-11-17 A | F4030 SS | 100% | ER365503 | ER365503 | 876 | 55 |  | LND | E | R | ER36 | 5503 | 2 | LND |  | 200 |  |
| ER425503 |  | CA55 SR5503 - Stress Calculation / Final Loads |  | 98d | 2009-11-16 A | 2010-04-09 A | F4030 FF | 100% | ER425503 | ER425503 | 872 | 55 |  | LND | E | R | ER42 | 5503 | PL | LND |  | 200 |  |
| ER195503 |  | CA55 SR5503 - Final Loads for Struc Steel | milestone | 0d | 2009-12-08 A | 2009-12-08 A | ER165503 FF, F4030 FF+5d, EN21550310 FF-10d | 100% | ER195503 | ER195503 | 876 | 55 |  | LNI | E | R | ER19 | 5503 | PL | LND |  | 200 |  |
| ER395503 |  | CA55 SR5503 - CAD Model Review 90% |  | 10d | 2010-06-28 A | 2010-07-09 A | F4460 FF | 100% | ER395503 | ER395503 | 876 | 55 |  | LND | E | R | ER39 | 5503 | 3 | LND |  | 200 |  |
| ER455503 |  | CA55 SR5503 - Piping Isometrics |  | 64d | 2010-08-23 A | 2010-11-19 A | ER425503, ER305503 FF, ER395503 FS+30d | 100% | ER455503 | ER455503 | 876 | 55 |  | LEI | E | R | ER45 | 5503 | 5 | LND |  | 200 |  |
| ER475503 |  | CA55 SR5503 - Piping Layout drwgs |  | 87d | 2010-09-17 A | 2011-01-20 A | ER305503, ER395503 FF+20d, ER475101 FF+18d | 100% | ER475503 | ER475503 | 876 | 55 |  | LEI | E | R | ER47 | 5503 | 5 | LND |  | 200 |  |
| ER445503 |  | CA55 SR5503 - Piping Isometrics (UG) |  | 25d | 2010-10-04 A | 2010-11-05 A | ER440000 FF, EC305503 SS+20d | 100% | ER445503 | ER445503 | 876 | 55 | E | LND | E | R | ER44 | 5503 | 4 | LND |  | 200 | 200 |
| ER495503 |  | CA55 SR5503 - Design Check / Release Isos & BOM |  | 79d | 2010-10-08 A | 2011-01-31 A | ER455503 FF | 100% | ER495503 | ER495503 | 876 | 55 |  | LEI | E | R | ER49 | 5503 | 5 | LND |  | 200 |  |

Notes:
- EC225503: P3 Activity Log Info: TKB-B Keyplan to Subcontractor
- EC45550305: P3 Activity Log Info: incl. PMT approval

| ID | WBS | Activity | Type | Duration | Start | Finish | Predecessors | Complete | Total float | Free float | Resources | UDF_SAVE ACTID | UDF_SAVE ACT ID | Department | Constr. Area | PMT-Phase | PMT-Respons. | WBS Phase | WBS Discipline | WBS Type of Work | WBS Objects | IMS | UPT | Pro Unit/DocCode | PMT-Area | TB26 Ressource Budget | Inquiry/Order No | Zeigen/n. Zeigen | Type of Work | PMT-Schedule Org | PMT-Discipline |
| --- | --- | --- | --- | --- | --- | --- | --- | --- | --- | --- | --- | --- | --- | --- | --- | --- | --- | --- | --- | --- | --- | --- | --- | --- | --- | --- | --- | --- | --- | --- | --- |
|  | E | **E Electrical** |  |  | 2008-10-06 | 2011-10-18 |  |  |  |  |  |  |  |  |  |  |  |  |  |  |  |  |  |  |  |  |  |  |  |  |  |
| EE46550305 |  | CA55 SR5503 - prelim Loads for Struc Steel |  | 15d | 2008-10-06 A | 2008-10-24 A | F3060 FF | 100% |  |  |  | EE46550305 | EE46550305 | 874 | 55 | E | LND | E | E | EE11 | 5503 | E | LND |  |  |  |  |  |  |  |  |
| EE905503 |  | CA55 SR5503 - Earthing Details |  | 30d | 2009-05-07 A | 2009-06-19 A | EE901201 SS | 100% |  |  |  | EE905503 | EE905503 | 874 | 55 | E | LND | E | E | EE90 | 5503 | E | LND |  |  |  |  |  |  |  |  |
| EE46550308 |  | CA55 SR5503 - Final Loads for Struc Steel |  | 20d | 2009-11-24 A | 2009-12-21 A | EE46550305 | 100% |  |  |  | EE46550308 | EE46550308 | 874 | 55 | E | LEI | E | E | EE12 | 5503 | E | LND |  |  |  |  |  |  |  |  |
| EE565503 |  | CA55 SR5503 - Cable Pulling Details |  | 164d | 2009-12-03 A | 2010-07-30 A | EE500130, EE46550310 FF | 100% |  |  |  | EE565503 | EE565503 | 874 | 55 | E | LEI | E | E | EE56 | 5503 | E | LND |  |  |  |  |  |  |  |  |
| EE46550310 |  | CA55 SR5503 - El. CableTray Layout Pl. 1st Issue |  | 197d | 2009-12-07 A | 2010-09-17 A | EE460000, F4030 FF+75d | 100% |  |  |  | EE46550310 | EE46550310 | 874 | 55 | E | LEI | E | E | EE46 | 5503 | E | LND |  |  |  |  |  |  |  |  |
| EE765503 |  | CA55 SR5503 - Layout Plan Light.& Sockets 1st Issue |  | 195d | 2010-01-26 A | 2010-10-29 A | EE000180 FS+10d | 100% |  |  |  | EE765503 | EE765503 | 874 | 55 | E | LEI | E | E | EE76 | 5503 | E | LND |  |  |  |  |  |  |  |  |
| EE46181010 |  | CA18 Chiller Unit Area - El. CableTray Layout Pl. 1st Issue |  | 32d | 2011-06-09 A | 2011-07-22 A | E3M1820 SF, E3A02D20 SS, E3M1720 FF, ER18000 FF | 100% |  |  |  | EE46550310 | EE46181010 | 874 | 18 | E | LEI | E | E | EE46 | 1810 | E | LND |  |  |  |  |  |  |  |  |
| EE46181020 |  | CA18 Chiller Unit Area - El. CableTray Layout Pl. final Issue |  | 25d | 2011-09-13 | 2011-10-18 | EE46181010, F4050 FF+15d |  | 418.5d | 0d |  | EE46550310 | EE46181020 | 874 | 18 | E | LEI | E | E | EE46 | 1810 | E | LND |  |  |  |  |  |  |  |  |
|  | J | **J Instrumentation** |  |  | 2008-10-06 | 2010-09-17 |  |  |  |  |  |  |  |  |  |  |  |  |  |  |  |  |  |  |  |  |  |  |  |  |  |
| EJ46550305 |  | CA55 SR5503 - prelim Loads for Struc Steel |  | 15d | 2008-10-06 A | 2008-10-24 A | F3060 FF | 100% |  |  |  | EJ46550305 | EJ46550305 | 86E | 55 | E | LND | E | J | EJ11 | 5503 | I | LND | 999 |  |  |  |  |  |  |  |
| EJ46550308 |  | CA55 SR5503 - Final Loads for Struc Steel |  | 10d | 2009-12-08 A | 2009-12-21 A | HEJ12 FF, EJ46550305 | 100% |  |  |  | EJ46550308 | EJ46550308 | 86E | 55 | E | LEI | E | J | EJ12 | 5503 | I | LND | 999 |  |  |  |  |  |  |  |
| EJ46550310 |  | CA55 SR5503 - Instr Cable Tray Layout Plans 1st Issue |  | 141d | 2010-03-01 A | 2010-09-17 A | F4460, F4030 FF, EE46550310 FF, HEJ46 FF | 100% |  |  |  | EJ46550310 | EJ46550310 | 86E | 55 | E | LEI | E | J | EJ41 | 5503 | I | LND | 999 |  |  |  |  |  |  |  |
|  | 56 | **56 CA56 - Piperack (between CA17/31/55)** |  |  | 2008-03-03 | 2011-01-21 |  |  |  |  |  |  |  |  |  |  |  |  |  |  |  |  |  |  |  |  |  |  |  |  |  |
|  | 5601 | **5601 Pipe Rack 6 - CA56** |  |  | 2008-03-03 | 2011-01-21 |  |  |  |  |  |  |  |  |  |  |  |  |  |  |  |  |  |  |  |  |  |  |  |  |  |
|  | C | **C Civil** |  |  | 2010-02-08 | 2010-09-20 |  |  |  |  |  |  |  |  |  |  |  |  |  |  |  |  |  |  |  |  |  |  |  |  |  |
| EC225601 |  | CA56 SR5601 - Layout Drwg / Loads IFD |  | 10d | 2010-02-08 A | 2010-02-19 A | EN255601 | 100% |  |  |  | EC225601 | EC225601 | 87A | 56 |  | LND | E | C | EC22 | 5601 | de | LND | 5600C01 | 200 |  |  |  |  |  |  |
| EC155601 |  | CA56 SR5601 - Piling drwgs AFC |  | 44d | 2010-02-22 A | 2010-04-26 A | IMS-E-000130 FF, EC265601 SS | 100% |  |  |  | EC155601 | EC155601 | 87A | 56 |  | IPR | E | C | EC15 | 5601 | PI | LND | 5601C16 | 200 |  |  |  |  |  |  |
| EC265601 |  | CA56 SR5601 - Civil Static Calc Fdtn |  | 147d | 2010-02-22 A | 2010-09-20 A | EC265102 SS+15d, P3C0BD FS+45d, EC225601 | 100% |  |  |  | EC265601 | EC265601 | 87A | 56 |  | IPR | E | C | EC26 | 5601 | de | LND | 5601C14 | 200 |  |  |  |  |  |  |
| EC45560105 |  | CA56 SR5601 - Civil Layout drwgs AFC |  | 109d | 2010-02-22 A | 2010-07-28 A | EC265601 SS, P3C0BD FS+10d, AD2230, EC225601 | 100% |  |  |  | EC45560105 | EC45560105 | 87A | 56 | E | IPR | E | C | EC45 | 5601 | ar | LND | 5601C13 | 200 |  |  |  |  |  |  |
| EC075605 |  | CA56 SR5601 - Issue of working drwgs (AFC) by RDI |  | 111d | 2010-03-22 A | 2010-08-27 A | EC285601 FF, EC45560105 SS+20d | 100% |  |  | TKB-B [480 h] | EC075605 | EC075605 | 87A | 56 | E | IPR | E | C | EC07 | 5601 | cq | LND | 1010C13 | 200 | 480,00 | 999 | FL |  |  |  |
| EC075600 |  | CA56 SR5601 - Check & Release of working drwgs (AFC) |  | 108d | 2010-03-29 A | 2010-08-31 A | EC45560105 SS+25d, EC285601 FF+5d | 100% |  |  | TKB-B [72 h] | EC075600 | EC075600 | 87A | 56 | E | LND | E | C | EC07 | 5601 | cq | LND |  | 200 | 72,00 | 999 | FL |  |  |  |
| EC285601 |  | CA56 SR5601 - Formw/Reinforce drwgs AFC |  | 81d | 2010-03-29 A | 2010-07-23 A | EC155601 SS+15d, EC265601 SS+25d | 100% |  |  |  | EC285601 | EC285601 | 87A | 56 |  | IPR | E | C | EC28 | 5601 | cq | LND | 5601C21 | 200 |  |  |  |  |  |  |
|  | N | **N Structural Steel** |  |  | 2008-03-03 | 2010-12-20 |  |  |  |  |  |  |  |  |  |  |  |  |  |  |  |  |  |  |  |  |  |  |  |  |  |
| EN155601 |  | CA56 SR5601 - CAD Model/Concepts StrSteel |  | 126d | 2008-03-03 A | 2008-08-29 A | EN155503 FF, EN155502 FF | 100% |  |  |  | EN155601 | EN155601 | 87B | 56 | E | LND | E | N | EN15 | 5601 | de | LND |  | 200 |  | N01J | 0 | N01J | 200 | 055 |
| EN21560105 |  | CA56 SR5601 - GA-Drwgs + Fdtn Loads |  | 15d | 2009-03-09 A | 2009-03-27 A | EJ46560105, ER165601, EE46560105, AD2230 FS+50d, EN155601 | 100% |  |  |  | EN21560105 | EN21560105 | 87B | 56 |  | LND | E | N | EN21 | 5601 | de | LND |  | 200 |  | N01J |  | N01J |  |  |
| EN24560105 |  | CA56 SR5601 - Static Calc for Fdtn Loads |  | 24d | 2009-11-16 A | 2009-12-18 A | EN24550305 FF+15d, EN21560105 | 100% |  |  | TKB-S [80 h] | EN24560105 | EN24560105 | 87B | 56 |  | LND | E | N | EN24 | 5601 | de | LND |  | 200 | 80,00 | N01J |  | N01J |  |  |
| EN255601 |  | CA56 SR5601 - Loads for Civil | milestone | 0d | 2009-12-18 A | 2009-12-18 A | EN24560105 FF, HEN25 FF | 100% |  |  |  | EN255601 | EN255601 | 87B | 56 | E | LND | E | N | EN25 | 5601 | de | LND |  | 200 |  | N01J | 0 | N01J | 200 | 055 |
| EN21560110 |  | CA56 SR5601 - GA-Drwgs + Final Loads |  | 103d | 2009-12-21 A | 2010-05-21 A | EE46560108 FF, EN21560105 FS+10d, EJ46560108 FF, ER425601, EN24560105, HEN21 FF | 100% |  |  | TKB-S [320 h] | EN21560110 | EN21560110 | 87B | 56 |  | LEI | E | N | EN21 | 5601 | de | LND |  | 200 | 320,00 | N01J |  | N01J |  |  |
| EN24560110 |  | CA56 SR5601 - Final Static Calc |  | 130d | 2009-12-30 A | 2010-07-07 A | EN21560110 SS, ER195601 FF | 100% |  |  | TKB-S [480 h] | EN24560110 | EN24560110 | 87B | 56 |  | LND | E | N | EN24 | 5601 | de | LND |  | 200 | 480,00 | N01J |  | N01J |  |  |
| EN265601 |  | CA56 SR5601 - Layout dwgs input for KM dwgs |  | 65d | 2010-04-26 A | 2010-07-27 A | HEN26 FF, EN24560110 FF+10d, F4030 FF+20d | 100% |  |  | TKB-S [640 h] | EN265601 | EN265601 | 87B | 56 |  | LND | E | N | EN26 | 5601 | st | LND |  | 200 | 640,00 | N01J |  | N01J |  |  |
| EN675601 |  | CA56 SR5601 - Grating Cut-Out drwgs |  | 85d | 2010-05-26 A | 2010-09-21 A | EN265601 FS+10d, F4460 FF+10d, ER425601 FF | 100% |  |  | TKB-S [160 h] | EN675601 | EN675601 | 87B | 56 | C | LND | E | N | EN67 | 5601 | de | LND |  | 200 | 160,00 | N01J |  | N01J | 200 |  |
| EN27560105 |  | CA56 SR5601 - KM drwgs |  | 64d | 2010-08-03 A | 2010-10-29 A | EN24560105, EN265601, E3C170 FF | 100% |  |  | KM Drwgs preparation by Cheljabinsk [75 t] | EN27560105 | EN27560105 | 87B | 56 |  | Chel | E | N | EN27 | 5601 | de | LND |  | 200 | 0,00 | N01J |  | N01J |  |  |
| EN645601 |  | CA56 SR5601 - Check Grating Cut-Out drwgs |  | 33d | 2010-09-22 A | 2010-11-05 A | EN675601 | 100% |  |  |  | EN645601 | EN645601 | 87B | 56 | C | LEI | E | N | EN67 | 5601 | de | LND |  | 200 |  | N01J |  | N01J | 200 |  |
| EN27560110 |  | CA56 SR5601 - Check KM drwgs |  | 11d | 2010-10-22 A | 2010-11-05 A | EN27560105 FF+4d, E3C170 FF | 100% |  |  |  | EN27560110 | EN27560110 | 87B | 56 |  | LND | E | N | EN27 | 5601 | de | LND |  | 200 |  | N01J |  | N01J |  |  |
| EN285601 |  | CA56 SR5601 - Shop dwgs(KMD) by Vendor |  | 30d | 2010-11-08 A | 2010-12-20 A | EN27560110, HEN28 FF | 100% |  |  |  | EN285601 | EN285601 | 87B | 56 |  | Chel | E | N | EN28 | 5601 | de | LND |  | 200 |  | N01J |  | N01J |  |  |
| EN685601 |  | CA56 SR5601 - Grating Fabrication drwgs |  | 25d | 2010-11-08 A | 2010-12-13 A | EN645601, EN675601 | 100% |  |  |  | EN685601 | EN685601 | 87B | 56 | C | Chel | E | N | EN68 | 5601 | de | LND |  | 200 |  | N01J |  | N01J | 200 |  |

Notes:
- EC225601: P3 Activity Log Info: TKB-B Keyplan to Subcontractor
- EC45560105: P3 Activity Log Info: incl. PMT approval

| ID | WBS | Activity | Type | Duration | Start | Finish | Predecessors | Complete | Resources | UDF_SAVE ACTID | UDF_SAVE ACT ID | Department | Constr. Area | PMT-Area | PMT-Respons. | WBS Phase | WBS Discipline | WBS Type of Work | WBS Objects | IMS | UPT | PMT-Schedule Org | PMT-Phase | Pro Unit/DocCode | TB26 Ressource Budget |
| --- | --- | --- | --- | --- | --- | --- | --- | --- | --- | --- | --- | --- | --- | --- | --- | --- | --- | --- | --- | --- | --- | --- | --- | --- | --- |
|  | R | **R Piping** |  |  | 2008-04-01 | 2010-11-22 |  |  |  |  |  |  |  |  |  |  |  |  |  |  |  |  |  |  |  |
| ER155601 |  | CA56 SR5601 - Conceptual Piping |  | 169d | 2008-04-01 A | 2008-11-28 A | ER155502 FF+10d, F2760 | 100% |  | ER155601 | ER155601 | 876 | 56 | 200 | LND | E | R | ER15 | 5601 | PL | LND |  |  |  |  |
| ER305601 |  | CA56 SR5601 - CAD Model Piping / Equipment |  | 511d | 2008-06-02 A | 2010-06-16 A | ER365601 FF+20d, ER395601 FF+10d | 100% |  | ER305601 | ER305601 | 876 | 56 | 200 | LNI | E | R | ER30 | 5601 | PL | LND |  |  |  |  |
| ER165601 |  | CA56 SR5601 - prelim Loads for Struc Steel |  | 20d | 2009-01-05 A | 2009-01-30 A | ER155601 FF | 100% |  | ER165601 | ER165601 | 876 | 56 | 200 | LND | E | R | ER16 | 5601 | PL | LND |  |  |  |  |
| ER365103 |  | CA51 SR5103 - CAD Model Review 60% |  | 12d | 2009-11-02 A | 2009-11-17 A | F4030 SS | 100% |  | ER365103 | ER365103 | 876 | 56 | 200 | LND | E | R | ER36 | 5601 | 2 | LND |  |  |  |  |
| ER365601 |  | CA56 SR5601 - CAD Model Review 60% |  | 12d | 2009-11-02 A | 2009-11-17 A | F4030 SS | 100% |  | ER365601 | ER365601 | 876 | 56 | 200 | LND | E | R | ER36 | 5601 | 2 | LND |  |  |  |  |
| ER425601 |  | CA55 SR5601 - Stress Calculation / Final Loads |  | 98d | 2009-11-16 A | 2010-04-09 A | F4030 FF | 100% |  | ER425601 | ER425601 | 872 | 56 | 200 | LND | E | R | ER42 | 5601 | PL | LND |  |  |  |  |
| ER195601 |  | CA56 SR5601 - Final Loads for Struc Steel | milestone | 0d | 2010-01-04 A | 2010-01-04 A | EN21560110 FF-10d, F4030 FF+5d, ER165601 FF | 100% |  | ER195601 | ER195601 | 876 | 56 | 200 | LNI | E | R | ER19 | 5601 | PL | LND |  |  |  |  |
| ER395601 |  | CA56 SR5601 - CAD Model Review 90% |  | 10d | 2010-04-26 A | 2010-05-07 A | F9250 FF | 100% |  | ER395601 | ER395601 | 876 | 56 | 200 | LND | E | R | ER39 | 5601 | 3 | LND |  |  |  |  |
| ER45560105 |  | CA56 SR5601 - Piping Isometrics (ZEP) |  | 53d | 2010-08-23 A | 2010-11-03 A | ER395601 FS+10d, ER305601 FF+10d, ER425601 | 100% |  | ER45560105 | ER45560105 | 876 | 56 | 200 | ZEP | E | R | ER45 | 5601 | 5 | LND |  |  |  |  |
| ER475601 |  | CA56 SR5601 - Piping Layout drwgs |  | 38d | 2010-09-17 A | 2010-11-09 A | ER305601, ER395601 FF+20d | 100% |  | ER475601 | ER475601 | 876 | 56 | 200 | LND | E | R | ER47 | 5601 | 5 | LND |  |  |  |  |
| ER455601 |  | CA56 SR5601 - Piping Isometrics |  | 40d | 2010-09-27 A | 2010-11-22 A | ER305601 FF+10d, ER455501 FF, ER395601, ER425601 | 100% |  | ER455601 | ER455601 | 876 | 56 | 200 | LEI | E | R | ER45 | 5601 | 5 | LND |  |  |  |  |
| ER445601 |  | CA56 SR5601 - Piping Isometrics (UG) |  | 20d | 2010-10-11 A | 2010-11-05 A | ER440000 FF, EC305601 SS+20d | 100% |  | ER445601 | ER445601 | 876 | 56 | 200 | LND | E | R | ER44 | 5601 | 4 | LND | 200 | E |  |  |
| ER495601 |  | CA56 SR5601 - Design Check / Release Isos & BOM |  | 26d | 2010-10-15 A | 2010-11-22 A | ER45560105 FF, ER455601 FF | 100% |  | ER495601 | ER495601 | 876 | 56 | 200 | LND | E | R | ER49 | 5601 | 5 | LND |  |  |  |  |
| ER49560105 |  | CA56 SR5601 - Design Check /Release Isos&BOM ZEP |  | 26d | 2010-10-15 A | 2010-11-22 A | ER45560105 FF, ER455601 FF | 100% |  | ER49560105 | ER49560105 | 876 | 56 | 200 | ZEP | E | R | ER49 | 5601 | 5 | LND |  |  |  |  |
|  | E | **E Electrical** |  |  | 2008-10-06 | 2010-10-29 |  |  |  |  |  |  |  |  |  |  |  |  |  |  |  |  |  |  |  |
| EE46560105 |  | CA56 SR5601 - prelim Loads for Struc Steel |  | 10d | 2008-10-06 A | 2008-10-17 A | F3060 FF | 100% |  | EE46560105 | EE46560105 | 874 | 56 |  | LND | E | E | EE11 | 5601 | E | LND |  | E |  |  |
| EE905601 |  | CA56 SR5601 - Earthing Details |  | 30d | 2009-04-06 A | 2009-05-20 A | EE900070, EE903110 | 100% |  | EE905601 | EE905601 | 874 | 56 |  | LND | E | E | EE90 | 5601 | E | LND |  | E |  |  |
| EE46560110 |  | CA56 SR5601 - El. CableTray Layout Pl. 1st Issue |  | 197d | 2009-12-07 A | 2010-09-17 A | EE460000, F4030 FF+75d | 100% |  | EE46560110 | EE46560110 | 874 | 56 |  | LEI | E | E | EE46 | 5601 | E | LND |  | E |  |  |
| EE565601 |  | CA56 SR5601 - Cable Pulling Details |  | 159d | 2009-12-10 A | 2010-07-30 A | EE500130, EE46560110 FF | 100% |  | EE565601 | EE565601 | 874 | 56 |  | LEI | E | E | EE56 | 5601 | E | LND |  | E |  |  |
| EE46560108 |  | CA56 SR5601 - Final Loads for Struc Steel |  | 50d | 2009-12-15 A | 2010-02-26 A | EE46560105 | 100% |  | EE46560108 | EE46560108 | 874 | 56 |  | LEI | E | E | EE12 | 5601 | E | LND |  | E |  |  |
| EE765601 |  | CA56 SR5601 - Layout Plan Light.& Sockets 1st Issue |  | 195d | 2010-01-26 A | 2010-10-29 A | EE000180 FS+10d | 100% |  | EE765601 | EE765601 | 874 | 56 |  | LEI | E | E | EE76 | 5601 | E | LND |  | E |  |  |
|  | J | **J Instrumentation** |  |  | 2008-10-06 | 2011-01-21 |  |  |  |  |  |  |  |  |  |  |  |  |  |  |  |  |  |  |  |
| EJ46560105 |  | CA56 SR5601 - prelim Loads for Struc Steel |  | 15d | 2008-10-06 A | 2008-10-24 A | F3060 FF | 100% |  | EJ46560105 | EJ46560105 | 86E | 56 |  | LND | E | J | EJ11 | 5601 | I | LND |  | E | 999 |  |
| EJ46560108 |  | CA56 SR5601 - Final Loads for Struc Steel |  | 10d | 2010-02-15 A | 2010-02-26 A | HEJ12 FF, EJ46560105 | 100% |  | EJ46560108 | EJ46560108 | 86E | 56 |  | LEI | E | J | EJ12 | 5601 | I | LND |  | E | 999 |  |
| EJ46560110 |  | CA56 SR5601 - Instr Cable Tray Layout Plans 1st Issue |  | 141d | 2010-03-01 A | 2010-09-17 A | EE46560110 FF, F4030 FF, HEJ46 FF, F4460 | 100% |  | EJ46560110 | EJ46560110 | 86E | 56 |  | LEI | E | J | EJ41 | 5601 | I | LND |  | E | 999 |  |
| EJ46510120 |  | General - Instr Cable Tray Layout Plans final Issue |  | 125d | 2010-07-28 A | 2011-01-21 A | F4030 FF, EE46510120 FF, EE46560110 FF, F4460, HEJ46 FF | 100% | TAP [3280 h] | EJ46510120 | EJ46510120 | 86E | 56 |  | LEI | E | J | EJ41 | 5601 | I | LND |  | E | 999 | 3280,00 |

| ID | WBS | Activity | Duration | Start | Finish | Predecessors | Complete | Resources | UDF_SAVE ACTID | UDF_SAVE ACT ID | Department | Constr. Area | PMT-Area | PMT-Schedule Org | PMT-Phase | PMT-Respons. | WBS Phase | WBS Discipline | WBS Type of Work | WBS Objects | IMS | UPT | TB26 Ressource Budget |
| --- | --- | --- | --- | --- | --- | --- | --- | --- | --- | --- | --- | --- | --- | --- | --- | --- | --- | --- | --- | --- | --- | --- | --- |
|  | 90 | **90 U/G Systems** |  | 2009-11-23 | 2011-01-28 |  |  |  |  |  |  |  |  |  |  |  |  |  |  |  |  |  |  |
|  | 90 | **90 U/G Systems - CA90** |  | 2009-11-23 | 2011-01-28 |  |  |  |  |  |  |  |  |  |  |  |  |  |  |  |  |  |  |
|  | C | **C Civil** |  | 2009-11-23 | 2011-01-28 |  |  |  |  |  |  |  |  |  |  |  |  |  |  |  |  |  |  |
| EC303110 |  | CA31 SiloStruc - UG Install dwgs (piping&concrete design) AFC | 272d | 2009-11-23 A | 2010-12-20 A | EC300000 FF, EC28311003 FF+10d | 100% |  | EC303110 | EC303110 | 87A | 90 | 200 | 200 | E | LNK | E | C | EC30 | 90 | cq | LND |  |
| EC303130 |  | CA31 Office Sec - UG Install dwgs (piping&concrete design) AFC | 272d | 2009-11-23 A | 2010-12-20 A | EC48313003 SS+20d, EC300000 FF | 100% |  | EC303130 | EC303130 | 87A | 90 | 200 | 200 | E | LNK | E | C | EC30 | 90 | cq | LND |  |
| EC303120 |  | CA31 Blower Sec - UG Install dwgs (piping&concrete design) AFC | 271d | 2009-11-24 A | 2010-12-20 A | EC48312003 SS+25d, EC300000 FF | 100% |  | EC303120 | EC303120 | 87A | 90 | 200 | 200 | E | LNK | E | C | EC30 | 90 | cq | LND |  |
| EC303140 |  | CA31 Warehouse - UG Install drwgs (piping&concrete design) AFC | 298d | 2009-11-24 A | 2011-01-28 A | EC48314003 SS+30d, EC300000 FF | 100% | TKB-B [4000 h] | EC303140 | EC303140 | 87A | 90 | 200 | 200 | E | LNK | E | C | EC30 | 90 | cq | LND | 4000,00 |
| EC151200 |  | CA12 General - UG Install drwgs (concrete works) AFC | 238d | 2010-02-22 A | 2011-01-28 A | EC28120105 SS+20d | 100% |  | EC151200 | EC151200 | 87A | 90 | 200 | 200 | E | IPR | E | C | EC30 | 90 | cq | LND |  |
| EC301000 |  | CA10 General - UG Install drwgs (concrete works) AFC | 238d | 2010-02-22 A | 2011-01-28 A | EC300000 SF | 100% |  | EC301000 | EC301000 | 87A | 90 | 200 | 200 | E | IPR | E | C | EC30 | 90 | cq | LND |  |
| EC301100 |  | CA11 General - UG Install drwgs (concrete works) AFC | 238d | 2010-02-22 A | 2011-01-28 A | EC281111 SS+10d, EC300000 SF, EC48111003 FF | 100% |  | EC301100 | EC301100 | 87A | 90 | 200 | 200 | E | IPR | E | C | EC30 | 90 | cq | LND |  |
| EC301300 |  | CA13 General - UG Install drwgs (concrete works) AFC | 238d | 2010-02-22 A | 2011-01-28 A | EC28130105 FF+5d, EC331200 FF, EC300000 FF, EC311200 FF, EC341200 FF, EC391200 FF, EC371200 FF, EC381200 FF, EC351200 FF | 100% |  | EC301300 | EC301300 | 87A | 90 | 200 | 200 | E | IPR | E | C | EC30 | 90 | cq | LND |  |
| EC301510 |  | CA15 Air Buffer - UG Install dwgs (concrete works) AFC | 238d | 2010-02-22 A | 2011-01-28 A | EC331200 FF, EC351200 FF, EC371200 FF, EC311200 FF, EC300000 FF, EC341200 FF, EC381200 FF, EC391200 FF | 100% |  | EC301510 | EC301510 | 87A | 90 | 200 | 200 | E | IPR | E | C | EC30 | 90 | cq | LND |  |
| EC301600 |  | CA16 Subst&RIE's - UG Install drwgs (concr work) AFC | 238d | 2010-02-22 A | 2011-01-28 A | EC300000 SS+10d, EC48161003 FF+5d | 100% |  | EC301600 | EC301600 | 87A | 90 | 200 | 200 | E | IPR | E | C | EC30 | 90 | cq | LND |  |
| EC301700 |  | CA17 General - UG Install drwgs outside ExtrBldg AFC | 238d | 2010-02-22 A | 2011-01-28 A | EC28170710 SF+10d, EC300000 SF, IMS-E-000150 FF | 100% | TKB-B [7040 h] | EC301700 | EC301700 | 87A | 90 | 200 | 200 | E | IPR | E | C | EC30 | 90 | cq | LND | 7040,00 |
| EC301707 |  | CA17 SR1707 - UG Install drwgs (concrete works) AFC | 238d | 2010-02-22 A | 2011-01-28 A | EC300000 SF, EC28170710 SF+10d, IMS-E-000150 FF | 100% |  | EC301707 | EC301707 | 87A | 90 | 200 | 200 | E | IPR | E | C | EC30 | 90 | cq | LND |  |
| EC301708 |  | CA17 SR1708 - UG Install drwgs (concrete works) AFC | 238d | 2010-02-22 A | 2011-01-28 A | EC311200 FF, EC331200 FF, EC341200 FF, IMS-E-000150 FF, EC371200 FF, EC381200 FF, EC391200 FF, EC28170810 SF+10d, EC351200 FF | 100% |  | EC301708 | EC301708 | 87A | 90 | 200 | 200 | E | IPR | E | C | EC30 | 90 | cq | LND |  |
| EC301710 |  | CA17 ExtrBldgFl1 - UG Install drwgs (concr work) AFC | 238d | 2010-02-22 A | 2011-01-28 A | EC28171010 SF+5d, EC48171003 FF+5d, EC300000 SF | 100% |  | EC301710 | EC301710 | 87A | 90 | 200 | 200 | E | IPR | E | C | EC30 | 90 | cq | LND |  |
| EC305101 |  | CA51 SR5101 - UG Install drwgs (concrete works) AFC | 238d | 2010-02-22 A | 2011-01-28 A | EC285101 SS+10d, EC300000 SF | 100% |  | EC305101 | EC305101 | 87A | 90 | 200 | 200 | E | IPR | E | C | EC30 | 90 | cq | LND |  |
| EC305102 |  | CA51 SR5102 - UG Install drwgs (concrete works) AFC | 238d | 2010-02-22 A | 2011-01-28 A | EC285102 SS+10d, EC300000 SF | 100% |  | EC305102 | EC305102 | 87A | 90 | 200 | 200 | E | IPR | E | C | EC30 | 90 | cq | LND |  |
| EC305103 |  | CA51 SR5103 - UG Install drwgs (concrete works) AFC | 238d | 2010-02-22 A | 2011-01-28 A | EC300000 SF, EC285103 SS+10d | 100% |  | EC305103 | EC305103 | 87A | 90 | 200 | 200 | E | IPR | E | C | EC30 | 90 | cq | LND |  |
| EC305104 |  | CA51 SR5104 - UG Install drwgs (concrete works) AFC | 238d | 2010-02-22 A | 2011-01-28 A | EC300000 SF, EC285104 SS+5d | 100% |  | EC305104 | EC305104 | 87A | 90 | 200 | 200 | E | IPR | E | C | EC30 | 90 | cq | LND |  |
| EC305201 |  | CA52 SR5201 - UG Install drwgs (concrete works) AFC | 238d | 2010-02-22 A | 2011-01-28 A | EC285201 SF+10d, EC300000 SF | 100% |  | EC305201 | EC305201 | 87A | 90 | 200 | 200 | E | IPR | E | C | EC30 | 90 | cq | LND |  |
| EC305301 |  | CA53 SR5301 - UG Install drwgs (concrete works) AFC | 238d | 2010-02-22 A | 2011-01-28 A | EC300000 FF, IMS-E-000150 FF | 100% |  | EC305301 | EC305301 | 87A | 90 | 200 | 200 | E | IPR | E | C | EC30 | 90 | cq | LND |  |
| EC305401 |  | CA54 SR5401 - UG Install drwgs (concrete works) AFC | 238d | 2010-02-22 A | 2011-01-28 A | EC285401 SF+15d, EC300000 SF | 100% |  | EC305401 | EC305401 | 87A | 90 | 200 | 200 | E | IPR | E | C | EC30 | 90 | cq | LND |  |
| EC305402 |  | CA54 SR5402 - UG Install drwgs (concrete works) AFC | 238d | 2010-02-22 A | 2011-01-28 A | EC285402 SF+5d, EC300000 SF | 100% |  | EC305402 | EC305402 | 87A | 90 | 200 | 200 | E | IPR | E | C | EC30 | 90 | cq | LND |  |
| EC305501 |  | CA55 SR5501 - UG Install drwgs (concrete works) AFC | 238d | 2010-02-22 A | 2011-01-28 A | EC285501 SF+10d, EC300000 SF | 100% |  | EC305501 | EC305501 | 87A | 90 | 200 | 200 | E | IPR | E | C | EC30 | 90 | cq | LND |  |
| EC305502 |  | CA55 SR5502 - UG Install drwgs (concrete works) AFC | 238d | 2010-02-22 A | 2011-01-28 A | EC285502 SF+10d, EC300000 SF | 100% |  | EC305502 | EC305502 | 87A | 90 | 200 | 200 | E | IPR | E | C | EC30 | 90 | cq | LND |  |
| EC305503 |  | CA55 SR5503 - UG Install drwgs (concrete works) AFC | 238d | 2010-02-22 A | 2011-01-28 A | EC285503 SF+10d | 100% |  | EC305503 | EC305503 | 87A | 90 | 200 | 200 | E | IPR | E | C | EC30 | 90 | cq | LND |  |
| EC305601 |  | CA56 SR5601 - UG Install drwgs (concrete works) AFC | 238d | 2010-02-22 A | 2011-01-28 A | EC381200 FF, EC371200 FF, EC305101 SS+20d, EC331200 FF, EC300000 SF, EC311200 FF, EC351200 FF, EC391200 FF, EC341200 FF | 100% |  | EC305601 | EC305601 | 87A | 90 | 200 | 200 | E | IPR | E | C | EC30 | 90 | cq | LND |  |

Notes:
- EC303110: P3 Activity Log Info: incl. Catch Basin and Pulling Pits
- EC303130: P3 Activity Log Info: incl. Catch Basin and Pulling Pits
- EC303120: P3 Activity Log Info: incl. Catch Basin and Pulling Pits
- EC303140: P3 Activity Log Info: incl. Catch Basin and Pulling Pits
- EC151200: P3 Activity Log Info: incl. Catch Basin and Pulling Pits
- EC301000: P3 Activity Log Info: incl. Catch Basin and Pulling Pits
- EC301100: P3 Activity Log Info: incl. Catch Basin and Pulling Pits
- EC301300: P3 Activity Log Info: incl. Catch Basin and Pulling Pits
- EC301510: P3 Activity Log Info: incl. Catch Basin and Pulling Pits
- EC301600: P3 Activity Log Info: incl. Catch Basin and Pulling Pits
- EC301700: P3 Activity Log Info: incl. Catch Basin and Pulling Pits
- EC301707: P3 Activity Log Info: incl. Catch Basin and Pulling Pits
- EC301708: P3 Activity Log Info: incl. Catch Basin and Pulling Pits
- EC301710: P3 Activity Log Info: incl. Catch Basin and Pulling Pits
- EC305101: P3 Activity Log Info: incl. Catch Basin and Pulling Pits
- EC305102: P3 Activity Log Info: incl. Catch Basin and Pulling Pits
- EC305103: P3 Activity Log Info: incl. Catch Basin and Pulling Pits
- EC305104: P3 Activity Log Info: incl. Catch Basin and Pulling Pits
- EC305201: P3 Activity Log Info: incl. Catch Basin and Pulling Pits
- EC305301: P3 Activity Log Info: incl. Catch Basin and Pulling Pits
- EC305401: P3 Activity Log Info: incl. Catch Basin and Pulling Pits
- EC305402: P3 Activity Log Info: incl. Catch Basin and Pulling Pits
- EC305501: P3 Activity Log Info: incl. Catch Basin and Pulling Pits
- EC305502: P3 Activity Log Info: incl. Catch Basin and Pulling Pits
- EC305503: P3 Activity Log Info: incl. Catch Basin and Pulling Pits
- EC305601: P3 Activity Log Info: incl. Catch Basin and Pulling Pits

| ID | WBS | Activity | Type | Duration | Start | Finish | Predecessors | Complete | UDF_SAVE ACTID | UDF_SAVE ACT ID | Department | Constr. Area | Pro Unit/DocCode | PMT-Area | PMT-Schedule Org | PMT-Phase | PMT-Respons. | WBS Phase | WBS Discipline | WBS Type of Work | WBS Objects | IMS | UPT |
| --- | --- | --- | --- | --- | --- | --- | --- | --- | --- | --- | --- | --- | --- | --- | --- | --- | --- | --- | --- | --- | --- | --- | --- |
|  | 90A | **90A U/G Syst. - CA90 - Oily Waste Water Sewer S.** |  |  | 2009-11-23 | 2010-12-03 |  |  |  |  |  |  |  |  |  |  |  |  |  |  |  |  |  |
|  | C | **C Civil** |  |  | 2009-11-23 | 2010-12-03 |  |  |  |  |  |  |  |  |  |  |  |  |  |  |  |  |  |
| EC313100 |  | CA90 W.W.Sewer S. - UG (down) Install dwgs | level of effort | 261d | 2009-11-23 A | 2010-12-03 A | EC303110 SS, EC303130 SS, EC303120 FF, EC303120 SS, EC303140 SS, EC303140 FF | 100% | EC313100 | EC313100 | 87A | 90 | 9031C90 | 200 | 200 | E | LNK | E | C | EC31 | 90A | cq | LND |
| EC44310010 |  | CA90 W.W.Sewer S. - UG (down) Gen.Drwgs&Doc | level of effort | 261d | 2009-11-23 A | 2010-12-03 A | EC303110 SS, EC303140 FF, EC513100 FF, EC303120 FF, EC303120 SS, EC303130 SS, EC303140 SS | 100% | EC44310010 | EC44310010 | 87A | 90 | 9030C11 | 200 | 200 | E | LNK | E | C | EC31 | 90A | cq | LND |
| EC513100 |  | CA90 W.W.Sewer S. - UG (down) Calculations | level of effort | 261d | 2009-11-23 A | 2010-12-03 A | EC313100 FF, EC313100 SS | 100% | EC513100 | EC513100 | 87A | 90 | 9031C14 | 200 | 200 | E | LNK | E | C | EC31 | 90A | cq | LND |
| EC311200 |  | CA90 W.W.Sewer S. - UG (up) Install dwgs | level of effort | 197d | 2010-02-22 A | 2010-11-30 A | EC301600 SS | 100% | EC311200 | EC311200 | 87A | 90 | 9001C90 | 200 | 200 | E | IPR | E | C | EC31 | 90A | cq | LND |
| EC511200 |  | CA90 W.W.Sewer S. - UG (up) Calculations | level of effort | 197d | 2010-02-22 A | 2010-11-30 A | EC311200 FF, EC311200 SS | 100% | EC511200 | EC511200 | 87A | 90 | 9001C14 | 200 | 200 | E | IPR | E | C | EC31 | 90A | cq | LND |
|  | 90C | **90C U/G Syst. - CA90 - Sanitary Waste Water Sewer S.** |  |  | 2009-11-23 | 2010-12-03 |  |  |  |  |  |  |  |  |  |  |  |  |  |  |  |  |  |
|  | C | **C Civil** |  |  | 2009-11-23 | 2010-12-03 |  |  |  |  |  |  |  |  |  |  |  |  |  |  |  |  |  |
| EC333100 |  | CA90 Sanitary W.W.S.S. - UG (down) Install dwgs | level of effort | 261d | 2009-11-23 A | 2010-12-03 A | EC303130 SS, EC303140 FF, EC303120 FF, EC303120 SS, EC303140 SS, EC303110 SS | 100% | EC333100 | EC333100 | 87A | 90 | 9033C90 | 200 | 200 | E | LNK | E | C | EC33 | 90C | cq | LND |
| EC533100 |  | CA90 Sanitary W.W.S.S. - UG (down) Calculations | level of effort | 261d | 2009-11-23 A | 2010-12-03 A | EC333100 FF, EC333100 SS | 100% | EC533100 | EC533100 | 87A | 90 | 9033C14 | 200 | 200 | E | LNK | E | C | EC33 | 90C | cq | LND |
| EC331200 |  | CA90 Sanitary W.W.S.S. - UG (up) Install dwgs | level of effort | 197d | 2010-02-22 A | 2010-11-30 A | EC301600 SS | 100% | EC331200 | EC331200 | 87A | 90 | 9003C90 | 200 | 200 | E | IPR | E | C | EC33 | 90C | cq | LND |
| EC531200 |  | CA90 Sanitary W.W.S.S. - UG (up) Calculations | level of effort | 197d | 2010-02-22 A | 2010-11-30 A | EC331200 FF, EC331200 SS | 100% | EC531200 | EC531200 | 87A | 90 | 9003C14 | 200 | 200 | E | IPR | E | C | EC33 | 90C | cq | LND |
|  | 90D | **90D U/G Syst. - CA90 - Medium Pressure Firewater S.** |  |  | 2009-11-23 | 2010-12-03 |  |  |  |  |  |  |  |  |  |  |  |  |  |  |  |  |  |
|  | C | **C Civil** |  |  | 2009-11-23 | 2010-12-03 |  |  |  |  |  |  |  |  |  |  |  |  |  |  |  |  |  |
| EC343100 |  | CA90 Med.Press.FW S. - UG (down) Install dwgs | level of effort | 261d | 2009-11-23 A | 2010-12-03 A | EC303110 SS, EC303120 FF, EC303120 SS, EC303140 FF, EC303140 SS, EC303130 SS | 100% | EC343100 | EC343100 | 87A | 90 | 9034C91 | 200 | 200 | E | LNK | E | C | EC34 | 90D | cq | LND |
| EC543100 |  | CA90 Med.Press.FW S. - UG (down) Calculations | level of effort | 261d | 2009-11-23 A | 2010-12-03 A | EC343100 SS, EC343100 FF | 100% | EC543100 | EC543100 | 87A | 90 | 9034C14 | 200 | 200 | E | LNK | E | C | EC34 | 90D | cq | LND |
| EC341200 |  | CA90 Med.Press.FW S. - UG (up) Install dwgs | level of effort | 197d | 2010-02-22 A | 2010-11-30 A | EC301600 SS | 100% | EC341200 | EC341200 | 87A | 90 | 9004C91 | 200 | 200 | E | IPR | E | C | EC34 | 90D | cq | LND |
| EC541200 |  | CA90 Med.Press.FW S. - UG (up) Calculations | level of effort | 197d | 2010-02-22 A | 2010-11-30 A | EC341200 FF, EC341200 SS | 100% | EC541200 | EC541200 | 87A | 90 | 9004C14 | 200 | 200 | E | IPR | E | C | EC34 | 90D | cq | LND |
|  | 90E | **90E U/G Syst. - CA90 - Potable Water Syst.** |  |  | 2009-11-23 | 2010-12-03 |  |  |  |  |  |  |  |  |  |  |  |  |  |  |  |  |  |
|  | C | **C Civil** |  |  | 2009-11-23 | 2010-12-03 |  |  |  |  |  |  |  |  |  |  |  |  |  |  |  |  |  |
| EC373100 |  | CA90 Potable W.S. - UG (down) Install dwgs | level of effort | 261d | 2009-11-23 A | 2010-12-03 A | EC303120 FF, EC303120 SS, EC303140 SS, EC303110 SS, EC303130 SS, EC303140 FF | 100% | EC373100 | EC373100 | 87A | 90 | 9037C92 | 200 | 200 | E | LNK | E | C | EC37 | 90E | cq | LND |
| EC573100 |  | CA90 Potable W.S. - UG (down) Calculations | level of effort | 261d | 2009-11-23 A | 2010-12-03 A | EC373100 SS, EC373100 FF | 100% | EC573100 | EC573100 | 87A | 90 | 9037C14 | 200 | 200 | E | LNK | E | C | EC37 | 90E | cq | LND |
| EC371200 |  | CA90 Potable W.S. - UG (up) Install dwgs | level of effort | 197d | 2010-02-22 A | 2010-11-30 A | EC301600 SS | 100% | EC371200 | EC371200 | 87A | 90 | 9007C92 | 200 | 200 | E | IPR | E | C | EC37 | 90E | cq | LND |
| EC571200 |  | CA90 Potable W.S. - UG (up) Calculations | level of effort | 197d | 2010-02-22 A | 2010-11-30 A | EC371200 SS, EC371200 FF | 100% | EC571200 | EC571200 | 87A | 90 | 9007C14 | 200 | 200 | E | IPR | E | C | EC37 | 90E | cq | LND |

Notes:
- EC313100: P3 Activity Log Info: incl. Catch Basin and Pulling Pits
- EC44310010: P3 Activity Log Info: incl. Catch Basin and Pulling Pits
- EC513100: P3 Activity Log Info: incl. Catch Basin and Pulling Pits
- EC311200: P3 Activity Log Info: incl. Catch Basin and Pulling Pits
- EC511200: P3 Activity Log Info: incl. Catch Basin and Pulling Pits
- EC333100: P3 Activity Log Info: incl. Catch Basin and Pulling Pits
- EC533100: P3 Activity Log Info: incl. Catch Basin and Pulling Pits
- EC331200: P3 Activity Log Info: incl. Catch Basin and Pulling Pits
- EC531200: P3 Activity Log Info: incl. Catch Basin and Pulling Pits
- EC343100: P3 Activity Log Info: incl. Catch Basin and Pulling Pits
- EC543100: P3 Activity Log Info: incl. Catch Basin and Pulling Pits
- EC341200: P3 Activity Log Info: incl. Catch Basin and Pulling Pits
- EC541200: P3 Activity Log Info: incl. Catch Basin and Pulling Pits
- EC373100: P3 Activity Log Info: incl. Catch Basin and Pulling Pits
- EC573100: P3 Activity Log Info: incl. Catch Basin and Pulling Pits
- EC371200: P3 Activity Log Info: incl. Catch Basin and Pulling Pits
- EC571200: P3 Activity Log Info: incl. Catch Basin and Pulling Pits

| ID | WBS | Activity | Type | Duration | Start | Finish | Predecessors | Complete | Resources | UDF_SAVE ACTID | UDF_SAVE ACT ID | Department | Constr. Area | Pro Unit/DocCode | PMT-Area | PMT-Schedule Org | PMT-Phase | PMT-Respons. | WBS Phase | WBS Discipline | WBS Type of Work | WBS Objects | IMS | UPT | TB26 Ressource Budget | Inquiry/Order No |
| --- | --- | --- | --- | --- | --- | --- | --- | --- | --- | --- | --- | --- | --- | --- | --- | --- | --- | --- | --- | --- | --- | --- | --- | --- | --- | --- |
|  | 90F | **90F U/G Syst. - CA90 - Service Water Syst.** |  |  | 2009-11-23 | 2010-12-03 |  |  |  |  |  |  |  |  |  |  |  |  |  |  |  |  |  |  |  |  |
|  | C | **C Civil** |  |  | 2009-11-23 | 2010-12-03 |  |  |  |  |  |  |  |  |  |  |  |  |  |  |  |  |  |  |  |  |
| EC383100 |  | CA90 Service W.S. - UG (down) Install dwgs | level of effort | 261d | 2009-11-23 A | 2010-12-03 A | EC303120 SS, EC303130 SS, EC303140 FF, EC303120 FF, EC303110 SS, EC303140 SS | 100% |  | EC383100 | EC383100 | 87A | 90 | 9038C92 | 200 | 200 | E | LNK | E | C | EC38 | 90F | cq | LND |  |  |
| EC583100 |  | CA90 Service W.S. - UG (down) Calculations | level of effort | 261d | 2009-11-23 A | 2010-12-03 A | EC383100 SS, EC383100 FF | 100% |  | EC583100 | EC583100 | 87A | 90 | 9038C14 | 200 | 200 | E | LNK | E | C | EC38 | 90F | cq | LND |  |  |
| EC381200 |  | CA90 Service W.S. - UG (up) Install dwgs | level of effort | 197d | 2010-02-22 A | 2010-11-30 A | EC301600 SS | 100% |  | EC381200 | EC381200 | 87A | 90 | 9008C92 | 200 | 200 | E | IPR | E | C | EC38 | 90F | cq | LND |  |  |
| EC581200 |  | CA90 Service W.S. - UG (up) Calculations | level of effort | 197d | 2010-02-22 A | 2010-11-30 A | EC381200 SS, EC381200 FF | 100% |  | EC581200 | EC581200 | 87A | 90 | 9008C14 | 200 | 200 | E | IPR | E | C | EC38 | 90F | cq | LND |  |  |
|  | 90G | **90G U/G Syst. - CA90 - Overall** |  |  | 2009-12-15 | 2010-11-30 |  |  |  |  |  |  |  |  |  |  |  |  |  |  |  |  |  |  |  |  |
|  | C | **C Civil** |  |  | 2009-12-15 | 2010-11-30 |  |  |  |  |  |  |  |  |  |  |  |  |  |  |  |  |  |  |  |  |
| EC39120005 |  | CA90 Overall - UG (up) Layout Drwgs / Loads IFD |  | 45d | 2009-12-15 A | 2010-02-19 A | EC301600 SF | 100% |  | EC39120005 | EC39120005 | 87A | 90 | 9600C01 | 200 | 200 | E | LND | E | C | EC39 | 90G | cq | LND |  |  |
| EC391200 |  | CA90 Overall - UG (up) Install dwgs | level of effort | 197d | 2010-02-22 A | 2010-11-30 A | EC301600 SS | 100% |  | EC391200 | EC391200 | 87A | 90 | 9000C12 | 200 | 200 | E | IPR | E | C | EC39 | 90G | cq | LND |  |  |
|  | 90H | **90H U/G Syst. - CA90 - High Pressure Firewater S.** |  |  | 2010-02-22 | 2010-11-30 |  |  |  |  |  |  |  |  |  |  |  |  |  |  |  |  |  |  |  |  |
|  | C | **C Civil** |  |  | 2010-02-22 | 2010-11-30 |  |  |  |  |  |  |  |  |  |  |  |  |  |  |  |  |  |  |  |  |
| EC351200 |  | CA90 HighPress.FW S. - UG (up) Install dwgs | level of effort | 197d | 2010-02-22 A | 2010-11-30 A | EC301600 SS | 100% |  | EC351200 | EC351200 | 87A | 90 | 9005C91 | 200 | 200 | E | IPR | E | C | EC34 | 90H | cq | LND |  |  |
| EC551200 |  | CA90 HighPress.FW S. - UG (up) Calculations | level of effort | 197d | 2010-02-22 A | 2010-11-30 A | EC351200 SS, EC351200 FF | 100% |  | EC551200 | EC551200 | 87A | 90 | 9005C14 | 200 | 200 | E | IPR | E | C | EC34 | 90H | cq | LND |  |  |
|  | 96 | **96 Concrete Paving** |  |  | 2008-07-14 | 2011-04-25 |  |  |  |  |  |  |  |  |  |  |  |  |  |  |  |  |  |  |  |  |
|  | 0000 | **0000 Generals - all CA's** |  |  | 2008-07-14 | 2010-12-13 |  |  |  |  |  |  |  |  |  |  |  |  |  |  |  |  |  |  |  |  |
|  | C | **C Civil** |  |  | 2008-07-14 | 2010-12-13 |  |  |  |  |  |  |  |  |  |  |  |  |  |  |  |  |  |  |  |  |
| EC24310010 |  | Overall Downstream - Linde Civil Layout Drwgs + Found Loads (IFD) | level of effort | 257d | 2008-07-14 A | 2009-07-24 A | EC443110 FF, EC443110 SS, EC443120 FF, EC443140 SS, EC443120 SS, EC443130 FF, EC443140 FF, EC443130 SS | 100% |  | EC24310010 | EC24310010 | 87A | 96 | 9030C01 | 200 | 200 | E | LND | E | C | EC15 | 0000 | de | LND |  |  |
| EC24120010 |  | Overall Upstream - Linde Civil Layout Drwgs + Found Loads (IFD) | level of effort | 598d | 2008-07-28 A | 2010-12-13 A | EC241110 FF, EC241710 FF, EC241111 FF, EC441222 FF, EC241510 FF, EC241322 SS, EC241010 SS, EC241222 FF, EC241230 FF, EC241130 FF, EC241511 FF, EC441710 SS, EC241322 FF, EC441322 FF, EC241330 FF, EC241110 SS, EC241233 FF, EC241710 SS, EC241321 SS, EC441321 SS, EC441321 FF, EC241330 SS, EC241332 FF, EC241232 SS, EC241511 SS, EC441221 FF, EC241230 SS, EC241130 SS, EC241510 SS, EC441610 SS, EC241321 FF, EC441322 SS, EC241332 SS, EC241111 SS, EC241221 FF, EC241232 FF, EC241233 SS, EC441110 FF, EC441110 SS, EC241221 SS, EC441221 SS, EC241222 SS, EC441222 SS, EC441610 FF, EC441710 FF | 100% |  | EC24120010 | EC24120010 | 87A | 96 | 9000C01 | 200 | 200 | E | LND | E | C | EC15 | 0000 | de | LND |  |  |
|  | 96 | **96 Concrete Paving - CA96** |  |  | 2009-11-24 | 2011-04-25 |  |  |  |  |  |  |  |  |  |  |  |  |  |  |  |  |  |  |  |  |
|  | C | **C Civil** |  |  | 2009-11-24 | 2011-04-25 |  |  |  |  |  |  |  |  |  |  |  |  |  |  |  |  |  |  |  |  |
| EC60310006 |  | CA95 Overall - Roads (down) dwgs AFC (outside) |  | 359d | 2009-11-24 A | 2011-04-25 A | EC603140 FF+10d, EC60310004 FF, EC603110 SS, EC603120 FF, EC603130 FF+10d | 100% | TKB-B [4640 h] | EC60310006 | EC60310006 | 87A | 96 | 9531C95 | 200 | 200 | E | LNK | E | C | EC60 | 9600 | de | LND | 4640,00 | 999 |
| EC0760 |  | CA96 Paving,Roads,Miscell. Drwgs - Check & Release of working drwgs (AFC) |  | 344d | 2009-12-15 A | 2011-04-25 A | EC601600 SS, EC601100 FF, EC601700 FF, EC601500 FF, EC45314015 SS, EC601300 SS, EC601000 FF, EC601200 SS, EC601400 FF | 100% | TKB-B [5456 h] | EC0760 | EC0760 | 87A | 96 | 9600C96 | 200 | 200 | E | LND | E | C | EC60 | 9600 | de | LND | 5456,00 |  |
| EC60310012 |  | CA96 Overall - Paving (down) Civil Layout Drwgs AFC |  | 284d | 2010-03-15 A | 2011-04-25 A | EC603130 SS, EC603130 FF+10d | 100% | TKB-B [2640 h] | EC60310012 | EC60310012 | 87A | 96 | 9631C13 | 200 | 200 | E | LNK | E | C | EC60 | 9600 | de | LND | 2640,00 | 999 |
| EC60120040 |  | CA96 Overall Upstream - Paving Calculations | level of effort | 253d | 2010-04-29 A | 2011-04-25 A | EC601400 FF, EC601700 FF, EC601100 FF, EC601500 FF, EC601300 SS, EC601600 SS-10d, EC601000 FF, EC601200 SS | 100% |  | EC60120040 | EC60120040 | 87A | 96 | 9600C14 | 200 | 200 | E | IPR | E | C | EC60 | 9600 | de | LND |  |  |
| EC60120050 |  | CA96 Overall Upstream - Paving Drwgs |  | 243d | 2010-05-14 A | 2011-04-25 A | EC601000 FF, EC601300 SS, EC601100 FF, EC601500 FF-12d, EC601600 SS, EC601400 FF-12d, EC601700 FF, EC601200 SS | 100% | TKB-B [18320 h] | EC60120050 | EC60120050 | 87A | 96 | 9600C96 | 200 | 200 | E | IPR | E | C | EC60 | 9600 | de | LND | 18320,00 |  |

Notes:
- EC383100: P3 Activity Log Info: incl. Catch Basin and Pulling Pits
- EC583100: P3 Activity Log Info: incl. Catch Basin and Pulling Pits
- EC381200: P3 Activity Log Info: incl. Catch Basin and Pulling Pits
- EC581200: P3 Activity Log Info: incl. Catch Basin and Pulling Pits
- EC39120005: P3 Activity Log Info: incl. Catch Basin and Pulling Pits
- EC391200: P3 Activity Log Info: incl. Catch Basin and Pulling Pits
- EC351200: P3 Activity Log Info: incl. Catch Basin and Pulling Pits
- EC551200: P3 Activity Log Info: incl. Catch Basin and Pulling Pits
- EC24310010: P3 Activity Log Info: incl. Catch Basin and Pulling Pits
- EC24120010: P3 Activity Log Info: incl. Catch Basin and Pulling Pits
- EC60310006: P3 Activity Log Info: incl. Catch Basin and / Pulling Pits
- EC0760: P3 Activity Log Info: incl. Catch Basin and / Pulling Pits
- EC60310012: P3 Activity Log Info: incl. Catch Basin and / Pulling Pits
- EC60120040: P3 Activity Log Info: incl. Catch Basin and Pulling Pits
- EC60120050: P3 Activity Log Info: incl. Catch Basin and / Pulling Pits

| ID | WBS | Activity | Type | Duration | Start | Finish | Predecessors | Complete | Resources | TB26 Ressource Budget | UDF_SAVE ACTID | UDF_SAVE ACT ID | Department | Constr. Area | Pro Unit/DocCode | PMT-Area | PMT-Schedule Org | PMT-Phase | PMT-Respons. | WBS Phase | WBS Discipline | WBS Type of Work | WBS Objects | IMS | UPT | Zeigen/n. Zeigen | PMT-Discipline |
| --- | --- | --- | --- | --- | --- | --- | --- | --- | --- | --- | --- | --- | --- | --- | --- | --- | --- | --- | --- | --- | --- | --- | --- | --- | --- | --- | --- |
|  | 98 | **98 Miscellaneous - CA98** |  |  | 2010-05-14 | 2011-04-25 |  |  |  |  |  |  |  |  |  |  |  |  |  |  |  |  |  |  |  |  |  |
|  | C | **C Civil** |  |  | 2010-05-14 | 2011-04-25 |  |  |  |  |  |  |  |  |  |  |  |  |  |  |  |  |  |  |  |  |  |
| EC65120060 |  | CA98 Overall Upstream - Misc. Drwgs |  | 243d | 2010-05-14 A | 2011-04-25 A | EC601500 FF-12d, EC601200 SS, EC601600 SS, EC601700 FF, EC601300 SS, EC601000 FF, EC601100 FF, EC601400 FF-12d | 100% | TKB-B [8480 h] | 8480,00 | EC65120060 | EC65120060 | 87A | 96 | 9600C96 | 200 | 200 | E | IPR | E | C | EC60 | 98 | de | LND |  |  |
|  | No CA | **No Constr. Area** |  |  | 2007-12-10 | 2011-05-30 |  |  |  |  |  |  |  |  |  |  |  |  |  |  |  |  |  |  |  |  |  |
|  | 0000 | **0000 Generals - all CA's** |  |  | 2007-12-10 | 2011-05-27 |  |  |  |  |  |  |  |  |  |  |  |  |  |  |  |  |  |  |  |  |  |
|  | C | **C Civil** |  |  | 2008-02-01 | 2011-04-25 |  |  |  |  |  |  |  |  |  |  |  |  |  |  |  |  |  |  |  |  |  |
| EC120 |  | Civil & Architectural Design | level of effort | 813d | 2008-02-01 A | 2011-04-25 A | F8860 SS, F1470 SS, F8820 SS | 100% |  |  | EC120 | EC120 | 87A |  |  |  |  | E | LND | E | C | EC00 | 0000 | de | LND | M1 |  |
|  | N | **N Structural Steel** |  |  | 2009-06-22 | 2011-05-27 |  |  |  |  |  |  |  |  |  |  |  |  |  |  |  |  |  |  |  |  |  |
| HEN25 |  | Loads for Civil | level of effort | 376d | 2009-06-22 A | 2010-12-13 A | EN253110 SS | 100% |  |  | HEN25 | HEN25 | 87B |  |  | 200 | 200 | E | LND | E | N | EN25 | 0000 | de | LND | L2 | 055 |
| HEN21 |  | Structural GA Dwgs + Final Loads | level of effort | 338d | 2009-10-12 A | 2011-02-11 A | EN21311010 SS, EN21311510 SS, EN21130110 SS, EN21171110 SS, EN21312010 SS, EN21120110 SS, EN21170110 SS | 100% |  |  | HEN21 | HEN21 | 87B |  |  | 200 | 200 | E | LND | E | N | EN25 | 0000 | de | LND | L2 | 055 |
| HEN26 |  | Structural Layout Dwgs (final for KM) | level of effort | 303d | 2010-01-04 A | 2011-03-11 A | EN261301 SS, EN263100 SS, EN261201 SS, EN261711 SS, EN263120 SS, EN261701 SS, EN26171101 SS, EN263110 SS, EN263115 SS | 100% |  |  | HEN26 | HEN26 | 87B |  |  | 200 | 200 | E | LND | E | N | EN25 | 0000 | st | LND | L2 | 055 |
| HEN80 |  | Structural Cladding Dwgs | level of effort | 160d | 2010-03-02 A | 2010-10-15 A | EN803120 FF, EN803130 SS | 100% |  |  | HEN80 | HEN80 | 87B |  |  | 200 | 200 | E | LND | E | N | EN25 | 0000 | de | LND | L2 | 055 |
| HEN28 |  | Structural Vendor Shop Dwgs (KMD) | level of effort | 175d | 2010-09-22 A | 2011-05-27 A | EN283110 SS, EN283115 SS, EN283120 SS, EN281301 SS, EN281711 SS, EN281701 SS, EN281201 SS | 100% |  |  | HEN28 | HEN28 | 87B |  |  | 200 | 200 | E | LND | E | N | EN25 | 0000 | de | LND | L2 | 055 |
| HEN68 |  | Structural Grating Fabrication Dwgs | level of effort | 140d | 2010-10-06 A | 2011-04-22 A | EN681711 SS, EN681760 SS, EN681770 SS, EN683110 SS, EN681301 SS, EN683115 SS, EN683120 SS, EN681201 SS | 100% |  |  | HEN68 | HEN68 | 87B |  |  | 200 | 200 | E | LND | E | N | EN25 | 0000 | de | LND | L2 | 055 |
|  | E | **E Electrical** |  |  | 2007-12-10 | 2011-03-21 |  |  |  |  |  |  |  |  |  |  |  |  |  |  |  |  |  |  |  |  |  |
| IMS-E-000190 |  | Electrical Design | level of effort | 822d | 2007-12-10 A | 2011-03-21 A | F1930 SS, F1000 SS | 100% |  |  | IMS-E-000190 | IMS-E-000190 | 874 |  |  |  |  | E | LND | E | E | EE00 | 0000 | E | LND | M1 |  |
| HEE20L |  | Techn. Eval./PO Spec's (Eqpt + Bulk LINDE Pck.) | level of effort | 633d | 2008-06-16 A | 2010-12-20 A | E3E2220 SS, E3E15B20 FF, E3E15A20 SS, E3E01A20 SS, E3E15C20 FF+10d, E3E15A20 FF+10d, E3E15C20 SS, E3E0220 SS, E3E0420 SS, E3E01B20 SS, E3E15B20 SS | 100% |  |  | HEE20L | HEE20L | 874 |  |  | 200 | 200 | E | LND | E | E | EE00 | 0000 | E | LND | L2 | 055 |
| HEE50 |  | Vendor Dwgs (Eqpt) approved | level of effort | 496d | 2008-11-24 A | 2010-11-12 A | E3E0450 | 100% |  |  | HEE50 | HEE50 | 874 |  |  | 200 | 200 | E | LND | E | E | EE00 | 0000 | P | LND | L2 | 055 |
| HEE12 |  | Final Loads for Civil / StrSteel | level of effort | 331d | 2009-08-31 A | 2010-12-20 A | EE46176008 FF, EE46130108 FF, EE46171808 FF, EE46120408 SS, EE46130408 SS, EE46113008 FF, EE46120108 FF, EE46170708 FF | 100% |  |  | HEE12 | HEE12 | 874 |  |  |  |  | E | LND | E | E | EE00 | 0000 | E | LND | L2 |  |
| HEE36 |  | Layout Plans LOP's | level of effort | 56d | 2009-12-07 A | 2010-02-26 A | EE46120110 SS | 100% |  |  | HEE36 | HEE36 | 874 |  |  |  |  | E | LEI | E | E | EE00 | 0000 | E | LND | L2 |  |
| HEE46 |  | CableTray Layout Plans / Cable Pulling Details | level of effort | 122d | 2009-12-07 A | 2010-06-04 A | EE46311010 SS, EE46161010 SS, EE46171010 SS, EE46312010 SS, EE46313010 SS | 100% |  |  | HEE46 | HEE46 | 874 |  |  |  |  | E | LND | E | E | EE00 | 0000 | E | LND | L2 |  |
| HEE92 |  | Fire Detection System Layout Dwgs | level of effort | 0d | 2010-10-01 A | 2010-10-01 A |  | 100% |  |  | HEE92 | HEE92 | 874 |  |  |  |  | E | LND | E | E | EE00 | 0000 | E | LND | L2 |  |
| HEE96 |  | Communication Sys Detail Dwgs | level of effort | 0d | 2010-10-01 A | 2010-10-01 A |  | 100% |  |  | HEE96 | HEE96 | 874 |  |  |  |  | E | LND | E | E | EE00 | 0000 | E | LND | L2 |  |
|  | 1300 | **1300 Generals - CA13** |  |  |  |  |  |  |  |  |  |  |  |  |  |  |  |  |  |  |  |  |  |  |  |  |  |
|  | E | **E Electrical** |  |  |  |  |  |  |  |  |  |  |  |  |  |  |  |  |  |  |  |  |  |  |  |  |  |
|  | LUZ2 | **LUZ2 General ( )** |  |  | 2008-12-08 | 2011-05-30 |  |  |  |  |  |  |  |  |  |  |  |  |  |  |  |  |  |  |  |  |  |
|  | N | **N Structural Steel** |  |  | 2010-03-17 | 2011-05-30 |  |  |  |  |  |  |  |  |  |  |  |  |  |  |  |  |  |  |  |  |  |
| E3C170 |  | KM Drwgs Structural Steel (last Drwgs CA14 Flare) | level of effort | 277d | 2010-03-17 A | 2011-04-18 A | EN27311005 SS, EN27312005 SS, EN27313005 SS, EN27314005 SS, EN27311505 SS | 100% |  |  | E3C170 | E3C170 | 87B |  |  |  |  | E | LND | E | N | 0000 | LUZ2 | de | LND | M1 |  |
| IMS-E-000180 |  | Structural Steel Shop Drwgs by Vendor for Construction | level of effort | 174d | 2010-09-24 A | 2011-05-30 A | EN285501 SS, EN283130 SS, EN283110 SS, EN285502 SS, EN285503 SS, EN283115 SS | 100% |  |  | IMS-E-000180 | IMS-E-000180 | 87B |  |  |  |  | E | LND | E | N | 0000 | LUZ2 | st | IMS |  |  |

Notes:
- EC65120060: P3 Activity Log Info: incl. Catch Basin and / Pulling Pits
- EC120: UDF_Actictity Name (Russia): Проектирование общестроительных работ
- HEN25: UDF_Actictity Name (Russia): Нагрузки по общестроительной части
- HEN21: UDF_Actictity Name (Russia): Конструкции, чертежи GA + окончательные нагрузки
- HEN26: UDF_Actictity Name (Russia): Конструкции, компоновочные чертежи (окончательные для KM)
- HEN80: UDF_Actictity Name (Russia): Конструкции, чертежи обшивки
- HEN28: UDF_Actictity Name (Russia): Конструкции, рабочие чертежи поставщиков (KMD)
- HEN68: UDF_Actictity Name (Russia): Конструкции, чертежи для изготовления настила
- IMS-E-000190: UDF_Actictity Name (Russia): Проектирование электрической части
- HEE20L: UDF_Actictity Name (Russia): Технический анализ/спецификации заказов на поставку (оборудование + насыпные материалы, пакет LINDE)
- HEE50: UDF_Actictity Name (Russia): Утверждение чертежей (оборудование) поставщиков
- HEE12: UDF_Actictity Name (Russia): Окончательные нагрузки по общестроительной части/металлоконструкциям
- HEE36: UDF_Actictity Name (Russia): Местные панели управления, компоновочные чертежи
- HEE46: UDF_Actictity Name (Russia): Схемы расположения кабельных лотков / детали прокладки кабелей
- HEE92: P3 Activity Log Info: (U&O) / UDF_Actictity Name (Russia): Система обнаружения пожара, компоновочные чертежи
- HEE96: P3 Activity Log Info: (U&O ??) / UDF_Actictity Name (Russia): Система связи, детальные чертежи

| ID | WBS | Activity | Duration | Start | Finish | Predecessors | Complete | Resources | UDF_SAVE ACTID | UDF_SAVE ACT ID | Department | Type of Work | Pro Unit/DocCode | PMT-Area | PMT-Schedule Org | PMT-Discipline | PMT-Phase | PMT-Respons. | Zeigen/n. Zeigen | WBS Phase | WBS Discipline | WBS Type of Work | WBS Objects | IMS | UPT | TB26 Ressource Budget |
| --- | --- | --- | --- | --- | --- | --- | --- | --- | --- | --- | --- | --- | --- | --- | --- | --- | --- | --- | --- | --- | --- | --- | --- | --- | --- | --- |
|  | J | **J Instrumentation** |  | 2008-12-08 | 2011-02-14 |  |  |  |  |  |  |  |  |  |  |  |  |  |  |  |  |  |  |  |  |  |
| EJ40300 |  | Cause&Effects/Logic Descrip. Review Utilities | 19d | 2008-12-08 A | 2009-01-08 A | EF40300 FF+10d, EF45300 FF+10d | 100% |  | EJ40300 | EJ40300 | 86C | J06A | 010 | 200 | 200 | 055 | E | LND | 0 | E | J | EJ16 | LUZ2 | I | LND |  |
| EJ40305 |  | Functional Design | 505d | 2008-12-08 A | 2010-12-10 A | EJ40390 FF, EJ40420 FF, EJ40410 FF | 100% |  | EJ40305 | EJ40305 | 86C | J06A | 400 | 200 | 200 | 055 | E | LND | 0 | E | J | EJ16 | LUZ2 | I | LND |  |
| EJ40211 |  | Cause&Effects/Logic Descrip. Review Unit 211 | 17d | 2009-01-08 A | 2009-01-30 A | EF40211 FF+10d, EF45211 FF+10d | 100% |  | EJ40211 | EJ40211 | 86C | J06A | 211 | 200 | 200 | 055 | E | LND | 0 | E | J | EJ16 | LUZ2 | I | LND |  |
| EJ40212 |  | Cause&Effects/Logic Descrip. Review Unit 212 | 15d | 2009-01-19 A | 2009-02-06 A | EF40212 FF+10d, EF45212 FF+10d | 100% |  | EJ40212 | EJ40212 | 86C | J06A | 212 | 200 | 200 | 055 | E | LND | 0 | E | J | EJ16 | LUZ2 | I | LND |  |
| EJ40210 |  | Cause&Effects/Logic Descrip. Review Unit 210 | 20d | 2009-02-02 A | 2009-02-27 A | EF40210 FF+10d, EF45210 FF+10d | 100% |  | EJ40210 | EJ40210 | 86C | J06A | 210 | 200 | 200 | 055 | E | LND | 0 | E | J | EJ16 | LUZ2 | I | LND |  |
| EJ40213 |  | Cause&Effects/Logic Descrip. Review Unit 213 | 15d | 2009-02-02 A | 2009-02-20 A | EF45213 FF+10d, EF40213 FF+10d | 100% |  | EJ40213 | EJ40213 | 86C | J06A | 213 | 200 | 200 | 055 | E | LND | 0 | E | J | EJ16 | LUZ2 | I | LND |  |
| EJ50211 |  | Logics (Narratives) Unit 211 (Break - Slow Down) | 42d | 2009-02-02 A | 2009-03-31 A | EF50211, EJ40211 | 100% |  | EJ50211 | EJ50211 | 86C | J06A | 211 | 200 | 200 | 055 | E | LND | 0 | E | J | EJ16 | LUZ2 | I | LND |  |
| EJ50300 |  | Logics (Narratives) Utilities (Break - Slow Down) | 33d | 2009-02-13 A | 2009-03-31 A | EF50300, EJ40300 | 100% |  | EJ50300 | EJ50300 | 86C | J06A | 010 | 200 | 200 | 055 | E | LND | 0 | E | J | EJ16 | LUZ2 | I | LND |  |
| EJ40218 |  | Cause&Effects/Logic Descrip. Review Unit 218 | 23d | 2009-02-18 A | 2009-03-20 A | EF45218 FF+10d, EF40218 FF+10d | 100% |  | EJ40218 | EJ40218 | 86C | J06A | 218 | 200 | 200 | 055 | E | LND | 0 | E | J | EJ16 | LUZ2 | I | LND |  |
| EJ50212 |  | Logics (Narratives) Unit 212 (Break - Slow Down) | 25d | 2009-02-25 A | 2009-03-31 A | EF50212, EJ40212 | 100% |  | EJ50212 | EJ50212 | 86C | J06A | 212 | 200 | 200 | 055 | E | LND | 0 | E | J | EJ16 | LUZ2 | I | LND |  |
| EJ50213 |  | Logics (Narratives) Unit 213 (Break - Slow Down) | 25d | 2009-02-25 A | 2009-03-31 A | EJ40213, EF50213 | 100% |  | EJ50213 | EJ50213 | 86C | J06A | 213 | 200 | 200 | 055 | E | LND | 0 | E | J | EJ16 | LUZ2 | I | LND |  |
| EJ50210 |  | Logics (Narratives) Unit 210 (Break - Slow Down) | 22d | 2009-03-02 A | 2009-03-31 A | EF50210, EJ40210 | 100% |  | EJ50210 | EJ50210 | 86C | J06A | 210 | 200 | 200 | 055 | E | LND | 0 | E | J | EJ16 | LUZ2 | I | LND |  |
| EJ40214 |  | Cause&Effects/Logic Descrip. Review Unit 214 (Break - Slow Down) | 7d | 2009-03-23 A | 2009-03-31 A | EF45214 FF+10d, EF40214 FF+10d | 100% |  | EJ40214 | EJ40214 | 86C | J06A | 214 | 200 | 200 | 055 | E | LND | 0 | E | J | EJ16 | LUZ2 | I | LND |  |
| EJ40215 |  | Cause&Effects/Logic Descrip. Review Unit 215 (Break - Slow Down) | 7d | 2009-03-23 A | 2009-03-31 A | EF45215 FF+10d, EF40215 FF+10d | 100% |  | EJ40215 | EJ40215 | 86C | J06A | 215 | 200 | 200 | 055 | E | LND | 0 | E | J | EJ16 | LUZ2 | I | LND |  |
| EJ50218 |  | Logics (Narratives) Unit 218 (Break - Slow Down) | 7d | 2009-03-23 A | 2009-03-31 A | EJ40218, EF50218 | 100% |  | EJ50218 | EJ50218 | 86C | J06A | 218 | 200 | 200 | 055 | E | LND | 0 | E | J | EJ16 | LUZ2 | I | LND |  |
| EJ40360 |  | Sundstrand - Review Funct. Design Requirements | 393d | 2009-04-06 A | 2010-10-26 A | EF40360 FF+10d | 100% | TAP [1280 h] | EJ40360 | EJ40360 | 86C | J06A | 020 | 200 | 200 | 055 | E | LND | 0 | E | J | EJ16 | LUZ2 | I | LND | 1280,00 |
| EJ40340 |  | K-Tron - Review Funct. Design Requirements | 342d | 2009-04-14 A | 2010-08-20 A | EF40340 FF | 100% | TAP [2560 h] | EJ40340 | EJ40340 | 86C | J06A | 020 | 200 | 200 | 055 | E | LND | 0 | E | J | EJ16 | LUZ2 | I | LND | 2560,00 |
| EJ40330 |  | Zeppelin - Review Funct. Design Requirements | 382d | 2009-04-20 A | 2010-10-21 A | EF40330 FF | 100% | TAP [3840 h] | EJ40330 | EJ40330 | 86C | J06A | 020 | 200 | 200 | 055 | E | LND | 0 | E | J | EJ16 | LUZ2 | I | LND | 3840,00 |
| EJ60300 |  | Rev. Cause&Effects/Logic Descrip. Review Utilities | 25d | 2009-11-09 A | 2009-12-14 A | EJ40300 | 100% |  | EJ60300 | EJ60300 | 86C | J06A | 010 | 200 | 200 | 055 | E | LND | 0 | E | J | EJ16 | LUZ2 | I | LND |  |
| EJ60210 |  | Rev. Cause&Effects/Logic Descrip. Review Unit 210 | 45d | 2009-11-16 A | 2010-01-22 A | EJ40210 | 100% |  | EJ60210 | EJ60210 | 86C | J06A | 210 | 200 | 200 | 055 | E | LND | 0 | E | J | EJ16 | LUZ2 | I | LND |  |
| EJ60211 |  | Rev. Cause&Effects/Logic Descrip. Review Unit 211 | 45d | 2009-11-16 A | 2010-01-22 A | EJ40211 | 100% |  | EJ60211 | EJ60211 | 86C | J06A | 211 | 200 | 200 | 055 | E | LND | 0 | E | J | EJ16 | LUZ2 | I | LND |  |
| EJ60212 |  | Rev. Cause&Effects/Logic Descrip. Review Unit 212 | 45d | 2009-11-16 A | 2010-01-22 A | EJ40212 | 100% |  | EJ60212 | EJ60212 | 86C | J06A | 212 | 200 | 200 | 055 | E | LND | 0 | E | J | EJ16 | LUZ2 | I | LND |  |
| EJ60213 |  | Rev. Cause&Effects/Logic Descrip. Review Unit 213 | 45d | 2009-11-16 A | 2010-01-22 A | EJ40213 | 100% |  | EJ60213 | EJ60213 | 86C | J06A | 213 | 200 | 200 | 055 | E | LND | 0 | E | J | EJ16 | LUZ2 | I | LND |  |
| EJ60214 |  | Rev. Cause&Effects/Logic Descrip. Review Unit 214 | 45d | 2009-11-16 A | 2010-01-22 A | EJ40214 | 100% |  | EJ60214 | EJ60214 | 86C | J06A | 214 | 200 | 200 | 055 | E | LND | 0 | E | J | EJ16 | LUZ2 | I | LND |  |
| EJ60215 |  | Rev. Cause&Effects/Logic Descrip. Review Unit 215 | 45d | 2009-11-16 A | 2010-01-22 A | EJ40215 | 100% |  | EJ60215 | EJ60215 | 86C | J06A | 215 | 200 | 200 | 055 | E | LND | 0 | E | J | EJ16 | LUZ2 | I | LND |  |
| EJ60218 |  | Rev. Cause&Effects/Logic Descrip. Review Unit 218 | 45d | 2009-11-16 A | 2010-01-22 A | EJ40218 | 100% |  | EJ60218 | EJ60218 | 86C | J06A | 218 | 200 | 200 | 055 | E | LND | 0 | E | J | EJ16 | LUZ2 | I | LND |  |
| EJ40320 |  | JSW - Review Funct. Design Requirements | 246d | 2009-12-01 A | 2010-11-22 A | EF40320, EF40325 SS+10d | 100% | TAP [2560 h] | EJ40320 | EJ40320 | 86C | J06A | 020 | 200 | 200 | 055 | E | LND | 0 | E | J | EJ16 | LUZ2 | I | LND | 2560,00 |
| EJ40350 |  | Burckhardt - Review Funct. Design Requirements | 212d | 2009-12-07 A | 2010-10-08 A | EF40355 SS+10d, EF40350 FF+10d | 100% | TAP [1280 h] | EJ40350 | EJ40350 | 86C | J06A | 020 | 200 | 200 | 055 | E | LND | 0 | E | J | EJ16 | LUZ2 | I | LND | 1280,00 |
| EJ70212 |  | Rev. Logics (Narratives) Unit 212 | 45d | 2009-12-08 A | 2010-02-12 A | EJ60212 SS+15d, EJ50212 | 100% |  | EJ70212 | EJ70212 | 86C | J06A | 212 | 200 | 200 | 055 | E | LND | 0 | E | J | EJ16 | LUZ2 | I | LND |  |
| EJ70215 |  | Logics (Narratives) Unit 215 | 45d | 2009-12-08 A | 2010-02-12 A | EJ60215 SS+15d | 100% |  | EJ70215 | EJ70215 | 86C | J06A | 215 | 200 | 200 | 055 | E | LND | 0 | E | J | EJ16 | LUZ2 | I | LND |  |
| EJ70300 |  | Rev. Logics (Narratives) Utilities | 25d | 2009-12-08 A | 2010-01-15 A | EJ50300, EJ60300 SS+20d | 100% |  | EJ70300 | EJ70300 | 86C | J06A | 010 | 200 | 200 | 055 | E | LND | 0 | E | J | EJ16 | LUZ2 | I | LND |  |
| EJ00010 |  | Functional Block (FB)-Catalog | 30d | 2009-12-15 A | 2010-01-29 A |  | 100% | TAP [5296 h] | EJ00010 | EJ00010 | 86C | J06A | 000 | 200 | 200 | 055 | E | LND | 0 | E | J | EJ16 | LUZ2 | I | LND | 5296,00 |
| EJ70210 |  | Rev. Logics (Narratives) Unit 210 | 45d | 2009-12-15 A | 2010-02-19 A | EJ70300 FF, EJ60210 SS+20d, EJ50210 | 100% |  | EJ70210 | EJ70210 | 86C | J06A | 210 | 200 | 200 | 055 | E | LND | 0 | E | J | EJ16 | LUZ2 | I | LND |  |
| EJ70211 |  | Rev. Logics (Narratives) Unit 211 | 45d | 2009-12-15 A | 2010-02-19 A | EJ70210 FF, EJ50211, EJ60211 SS+20d | 100% |  | EJ70211 | EJ70211 | 86C | J06A | 211 | 200 | 200 | 055 | E | LND | 0 | E | J | EJ16 | LUZ2 | I | LND |  |
| EJ70213 |  | Rev. Logics (Narratives) Unit 213 | 45d | 2009-12-15 A | 2010-02-19 A | EJ50213, EJ60213 SS+20d | 100% |  | EJ70213 | EJ70213 | 86C | J06A | 213 | 200 | 200 | 055 | E | LND | 0 | E | J | EJ16 | LUZ2 | I | LND |  |
| EJ70214 |  | Logics (Narratives) Unit 214 | 45d | 2009-12-15 A | 2010-02-19 A | EJ60214 SS+20d | 100% |  | EJ70214 | EJ70214 | 86C | J06A | 214 | 200 | 200 | 055 | E | LND | 0 | E | J | EJ16 | LUZ2 | I | LND |  |
| EJ70218 |  | Rev. Logics (Narratives) Unit 218 | 45d | 2009-12-15 A | 2010-02-19 A | EJ50218, EJ60218 SS+20d | 100% |  | EJ70218 | EJ70218 | 86C | J06A | 218 | 200 | 200 | 055 | E | LND | 0 | E | J | EJ16 | LUZ2 | I | LND |  |
| EJ75212 |  | Sequences Unit 212 | 45d | 2010-01-04 A | 2010-03-05 A | EJ70212 SS+15d, EJ70211 FF, EJ60212 SS | 100% |  | EJ75212 | EJ75212 | 86C | J06A | 212 | 200 | 200 | 055 | E | LND | 0 | E | J | EJ16 | LUZ2 | I | LND |  |
| EJ75215 |  | Sequences Unit 215 | 45d | 2010-01-04 A | 2010-03-05 A | EJ60215 FF, EJ75212 FF, EJ70215 SS+15d | 100% |  | EJ75215 | EJ75215 | 86C | J06A | 215 | 200 | 200 | 055 | E | LND | 0 | E | J | EJ16 | LUZ2 | I | LND |  |
| EJ75214 |  | Sequences Unit 214 | 45d | 2010-01-11 A | 2010-03-12 A | EJ70214 SS+15d, EJ60214 FF, EJ75215 FF | 100% |  | EJ75214 | EJ75214 | 86C | J06A | 214 | 200 | 200 | 055 | E | LND | 0 | E | J | EJ16 | LUZ2 | I | LND |  |
| EJ75218 |  | Sequences Unit 218 | 45d | 2010-01-11 A | 2010-03-12 A | EJ60218 FF, EJ70218 SS+15d, EJ75214 FF | 100% |  | EJ75218 | EJ75218 | 86C | J06A | 218 | 200 | 200 | 055 | E | LND | 0 | E | J | EJ16 | LUZ2 | I | LND |  |
| EJ75213 |  | Sequences Unit 213 | 45d | 2010-01-18 A | 2010-03-19 A | EJ75218 FF, EJ70213 SS+20d, EJ60213 FF | 100% |  | EJ75213 | EJ75213 | 86C | J06A | 213 | 200 | 200 | 055 | E | LND | 0 | E | J | EJ16 | LUZ2 | I | LND |  |
| EJ00020 |  | Functional Block Design (FBD)-Catalog | 30d | 2010-01-25 A | 2010-03-05 A | EJ00010 FF+20d | 100% | TAP [3840 h] | EJ00020 | EJ00020 | 86C | J06A | 000 | 200 | 200 | 055 | E | LND | 0 | E | J | EJ16 | LUZ2 | I | LND | 3840,00 |
| EJ00025 |  | Functional Block Design (FBD)-Catalog-Interface PU | 30d | 2010-01-25 A | 2010-03-05 A | EJ00020 FF | 100% | TAP [2560 h] | EJ00025 | EJ00025 | 86C | J06A | 000 | 200 | 200 | 055 | E | LND | 0 | E | J | EJ16 | LUZ2 | I | LND | 2560,00 |
| EJ00035 |  | FBD Allocation | 25d | 2010-02-15 A | 2010-03-19 A | EJ00020 SS+10d | 100% | TAP [3840 h] | EJ00035 | EJ00035 | 86C | J06A | 000 | 200 | 200 | 055 | E | LND | 0 | E | J | EJ16 | LUZ2 | I | LND | 3840,00 |
| EJ85235 |  | Final Preparation Graphics (Process, PU's, Plant Util., Aut.Syst.) | 166d | 2010-02-15 A | 2010-10-08 A | EJ00025 SS+10d | 100% | TAP [1280 h] | EJ85235 | EJ85235 | 86C | J06A | 400 | 200 | 200 | 055 | E | LND | 0 | E | J | EJ16 | LUZ2 | I | LND | 1280,00 |
| EJ40370 |  | Beumer - Review Funct. Design Requirements | 177d | 2010-03-12 A | 2010-11-22 A | E3U0760 FF+30d | 100% | TAP [1280 h] | EJ40370 | EJ40370 | 86C | J06A | 020 | 200 | 200 | 055 | E | LND | 0 | E | J | EJ16 | LUZ2 | I | LND | 1280,00 |
| EJ00040 |  | DCS/SIS-I/O-Assignment | 23d | 2010-03-22 A | 2010-04-23 A | EJ00035, EJ00015 SS+1d | 100% | TAP [3840 h] | EJ00040 | EJ00040 | 86C | J06A | 000 | 200 | 200 | 055 | E | LND | 0 | E | J | EJ16 | LUZ2 | I | LND | 3840,00 |
| EJ80210 |  | FDS for DCS/SIS, Generic FBD's - Unit 210 | 55d | 2010-03-22 A | 2010-06-10 A | EJ00020 FS+10d | 100% | TAP [640 h] | EJ80210 | EJ80210 | 86C | J06A | 210 | 200 | 200 | 055 | E | LND | 0 | E | J | EJ16 | LUZ2 | I | LND | 640,00 |
| EJ80211 |  | FDS for DCS/SIS, Generic FBD's - Unit 211 | 50d | 2010-03-29 A | 2010-06-10 A | EJ80210 | 100% | TAP [640 h] | EJ80211 | EJ80211 | 86C | J06A | 211 | 200 | 200 | 055 | E | LND | 0 | E | J | EJ16 | LUZ2 | I | LND | 640,00 |
| EJ82210 |  | FDS for DCS/SIS, Logics for complex functions - Unit 210 | 55d | 2010-03-29 A | 2010-06-17 A | EJ80210 | 100% | TAP [1280 h] | EJ82210 | EJ82210 | 86C | J06A | 210 | 200 | 200 | 055 | E | LND | 0 | E | J | EJ16 | LUZ2 | I | LND | 1280,00 |
| EJ00015 |  | Update Functional Block (FB)-Catalog | 10d | 2010-04-01 A | 2010-04-16 A | EJ00010 FS+43d | 100% | TAP [1280 h] | EJ00015 | EJ00015 | 86C | J06A | 000 | 200 | 200 | 055 | E | LND | 0 | E | J | EJ16 | LUZ2 | I | LND | 1280,00 |
| EJ00030 |  | Update Functional Block Design (FBD)-Catalog | 10d | 2010-04-01 A | 2010-04-16 A | EJ00020 FS+23d | 100% | TAP [1280 h] | EJ00030 | EJ00030 | 86C | J06A | 000 | 200 | 200 | 055 | E | LND | 0 | E | J | EJ16 | LUZ2 | I | LND | 1280,00 |
| EJ80212 |  | FDS for DCS/SIS, Generic FBD's - Unit 212 | 46d | 2010-04-06 A | 2010-06-10 A | EJ80211 | 100% | TAP [640 h] | EJ80212 | EJ80212 | 86C | J06A | 212 | 200 | 200 | 055 | E | LND | 0 | E | J | EJ16 | LUZ2 | I | LND | 640,00 |
| EJ80221 |  | FDS for DCS/SIS, Generic FBD's - Unit 221 | 82d | 2010-04-06 A | 2010-07-30 A | EJ80211 SS | 100% | TAP [640 h] | EJ80221 | EJ80221 | 86C | J06A | 211 | 200 | 200 | 055 | E | LND | 0 | E | J | EJ16 | LUZ2 | I | LND | 640,00 |
| EJ80222 |  | FDS for DCS/SIS, Generic FBD's - Unit 222 | 87d | 2010-04-06 A | 2010-08-06 A | EJ80212 SS | 100% | TAP [640 h] | EJ80222 | EJ80222 | 86C | J06A | 212 | 200 | 200 | 055 | E | LND | 0 | E | J | EJ16 | LUZ2 | I | LND | 640,00 |
| EJ80230 |  | FDS for DCS/SIS, Generic FBD's - Unit 230 | 46d | 2010-04-06 A | 2010-06-10 A | EJ00020 | 100% | TAP [640 h] | EJ80230 | EJ80230 | 86C | J06A | 400 | 200 | 200 | 055 | E | LND | 0 | E | J | EJ16 | LUZ2 | I | LND | 640,00 |
| EJ82211 |  | FDS for DCS/SIS, Logics for complex functions - Unit 211 | 51d | 2010-04-06 A | 2010-06-17 A | EJ80211 | 100% | TAP [1280 h] | EJ82211 | EJ82211 | 86C | J06A | 211 | 200 | 200 | 055 | E | LND | 0 | E | J | EJ16 | LUZ2 | I | LND | 1280,00 |
| EJ82212 |  | FDS for DCS/SIS, Logics for complex functions - Unit 212 | 51d | 2010-04-06 A | 2010-06-17 A | EJ80212 | 100% | TAP [1280 h] | EJ82212 | EJ82212 | 86C | J06A | 212 | 200 | 200 | 055 | E | LND | 0 | E | J | EJ16 | LUZ2 | I | LND | 1280,00 |
| EJ82235 |  | FDS for DCS/SIS, Logics for complex functions - Unit 230 | 51d | 2010-04-06 A | 2010-06-17 A | EJ82210 FF, EJ80230 | 100% | TAP [1280 h] | EJ82235 | EJ82235 | 86C | J06A | 400 | 200 | 200 | 055 | E | LND | 0 | E | J | EJ16 | LUZ2 | I | LND | 1280,00 |
| EJ40380 |  | Instr. Air Compr. - Review Funct. Design Requirements | 164d | 2010-04-08 A | 2010-11-26 A | E3M1660 FF+10d | 100% | TAP [1280 h] | EJ40380 | EJ40380 | 86C | J06A | 020 | 200 | 200 | 055 | E | LND | 0 | E | J | EJ16 | LUZ2 | I | LND | 1280,00 |
| EJ80213 |  | FDS for DCS/SIS, Generic FBD's - Unit 213 | 42d | 2010-04-12 A | 2010-06-10 A | EJ80212 | 100% | TAP [640 h] | EJ80213 | EJ80213 | 86C | J06A | 213 | 200 | 200 | 055 | E | LND | 0 | E | J | EJ16 | LUZ2 | I | LND | 640,00 |
| EJ80214 |  | FDS for DCS/SIS, Generic FBD's - Unit 214 | 42d | 2010-04-12 A | 2010-06-10 A | EJ80213 FF | 100% | TAP [640 h] | EJ80214 | EJ80214 | 86C | J06A | 214 | 200 | 200 | 055 | E | LND | 0 | E | J | EJ16 | LUZ2 | I | LND | 640,00 |
| EJ80223 |  | FDS for DCS/SIS, Generic FBD's - Unit 223 | 83d | 2010-04-12 A | 2010-08-06 A | EJ80213 SS | 100% | TAP [640 h] | EJ80223 | EJ80223 | 86C | J06A | 213 | 200 | 200 | 055 | E | LND | 0 | E | J | EJ16 | LUZ2 | I | LND | 640,00 |
| EJ80224 |  | FDS for DCS/SIS, Generic FBD's - Unit 224 | 83d | 2010-04-12 A | 2010-08-06 A | EJ80214 SS | 100% | TAP [640 h] | EJ80224 | EJ80224 | 86C | J06A | 214 | 200 | 200 | 055 | E | LND | 0 | E | J | EJ16 | LUZ2 | I | LND | 640,00 |
| EJ82213 |  | FDS for DCS/SIS, Logics for complex functions - Unit 213 | 47d | 2010-04-12 A | 2010-06-17 A | EJ80213 | 100% | TAP [1280 h] | EJ82213 | EJ82213 | 86C | J06A | 213 | 200 | 200 | 055 | E | LND | 0 | E | J | EJ16 | LUZ2 | I | LND | 1280,00 |
| EJ82214 |  | FDS for DCS/SIS, Logics for complex functions - Unit 214 | 47d | 2010-04-12 A | 2010-06-17 A | EJ80214 FS+1d | 100% | TAP [1280 h] | EJ82214 | EJ82214 | 86C | J06A | 214 | 200 | 200 | 055 | E | LND | 0 | E | J | EJ16 | LUZ2 | I | LND | 1280,00 |
| EJ80218 |  | FDS for DCS/SIS, Generic FBD's - Unit 218 | 37d | 2010-04-19 A | 2010-06-10 A | EJ80214 FF | 100% | TAP [640 h] | EJ80218 | EJ80218 | 86C | J06A | 218 | 200 | 200 | 055 | E | LND | 0 | E | J | EJ16 | LUZ2 | I | LND | 640,00 |
| EJ80220 |  | FDS for DCS/SIS, Generic FBD's - Unit 220 | 78d | 2010-04-19 A | 2010-08-06 A | EJ80210 SS+15d | 100% | TAP [640 h] | EJ80220 | EJ80220 | 86C | J06A | 210 | 200 | 200 | 055 | E | LND | 0 | E | J | EJ16 | LUZ2 | I | LND | 640,00 |

| ID | Activity | Duration | Start | Finish | Predecessors | Complete | Resources | TB26 Ressource Budget | UDF_SAVE ACTID | UDF_SAVE ACT ID | Department | Type of Work | Pro Unit/DocCode | PMT-Area | PMT-Schedule Org | PMT-Discipline | PMT-Phase | PMT-Respons. | Zeigen/n. Zeigen | WBS Phase | WBS Discipline | WBS Type of Work | WBS Objects | IMS | UPT |
| --- | --- | --- | --- | --- | --- | --- | --- | --- | --- | --- | --- | --- | --- | --- | --- | --- | --- | --- | --- | --- | --- | --- | --- | --- | --- |
| EJ82218 | FDS for DCS/SIS, Logics for complex functions - Unit 218 | 42d | 2010-04-19 A | 2010-06-17 A | EJ80218 FF | 100% | TAP [1280 h] | 1280,00 | EJ82218 | EJ82218 | 86C | J06A | 218 | 200 | 200 | 055 | E | LND | 0 | E | J | EJ16 | LUZ2 | I | LND |
| EJ84211 | FDS for DCS/SIS, Generic sequences - Unit 211 | 78d | 2010-04-19 A | 2010-08-06 A | EJ82211 FF | 100% | TAP [1280 h] | 1280,00 | EJ84211 | EJ84211 | 86C | J06A | 211 | 200 | 200 | 055 | E | LND | 0 | E | J | EJ16 | LUZ2 | I | LND |
| EJ84212 | FDS for DCS/SIS, Generic sequences - Unit 212 | 47d | 2010-04-19 A | 2010-06-24 A | EJ82212 FF+5d | 100% | TAP [1280 h] | 1280,00 | EJ84212 | EJ84212 | 86C | J06A | 212 | 200 | 200 | 055 | E | LND | 0 | E | J | EJ16 | LUZ2 | I | LND |
| EJ84213 | FDS for DCS/SIS, Generic sequences - Unit 213 | 47d | 2010-04-19 A | 2010-06-24 A | EJ82213 FF+5d | 100% | TAP [1280 h] | 1280,00 | EJ84213 | EJ84213 | 86C | J06A | 213 | 200 | 200 | 055 | E | LND | 0 | E | J | EJ16 | LUZ2 | I | LND |
| EJ84214 | FDS for DCS/SIS, Generic sequences - Unit 214 | 47d | 2010-04-19 A | 2010-06-24 A | EJ82214 FF+5d | 100% | TAP [1280 h] | 1280,00 | EJ84214 | EJ84214 | 86C | J06A | 214 | 200 | 200 | 055 | E | LND | 0 | E | J | EJ16 | LUZ2 | I | LND |
| EJ40390 | Flare - Review Funct. Design Requirements | 152d | 2010-04-26 A | 2010-11-26 A | E3A1840 FF, E3A1860 FF+15d | 100% | TAP [640 h] | 640,00 | EJ40390 | EJ40390 | 86C | J06A | 020 | 200 | 200 | 055 | E | LND | 0 | E | J | EJ16 | LUZ2 | I | LND |
| EJ40410 | Zeppelin Feeders, Vacuum - Review Funct. Design Requirements | 125d | 2010-04-26 A | 2010-10-19 A | E3U2250 FF, E3M1265 FF | 100% | TAP [2560 h] | 2560,00 | EJ40410 | EJ40410 | 86C | J06A | 020 | 200 | 200 | 055 | E | LND | 0 | E | J | EJ16 | LUZ2 | I | LND |
| EJ40420 | SIAD - Review Funct. Design Requirements | 142d | 2010-04-26 A | 2010-11-11 A | E3M0465 FF | 100% | TAP [1280 h] | 1280,00 | EJ40420 | EJ40420 | 86C | J06A | 020 | 200 | 200 | 055 | E | LND | 0 | E | J | EJ16 | LUZ2 | I | LND |
| EJ80235 | FDS for DCS/SIS, Generic FBD's - Plant Utilities (HVAC,SWG) | 128d | 2010-04-28 A | 2010-10-26 A | EJ80230 | 100% | TAP [640 h] | 640,00 | EJ80235 | EJ80235 | 86C | J06A | 400 | 200 | 200 | 055 | E | LND | 0 | E | J | EJ16 | LUZ2 | I | LND |
| EJ82221 | FDS for DCS/SIS, Logics for complex functions - Unit 221 | 71d | 2010-04-28 A | 2010-08-06 A | EJ80221 | 100% | TAP [640 h] | 640,00 | EJ82221 | EJ82221 | 86C | J06A | 211 | 200 | 200 | 055 | E | LND | 0 | E | J | EJ16 | LUZ2 | I | LND |
| EJ82222 | FDS for DCS/SIS, Logics for complex functions - Unit 222 | 76d | 2010-04-28 A | 2010-08-13 A | EJ80222 | 100% | TAP [640 h] | 640,00 | EJ82222 | EJ82222 | 86C | J06A | 212 | 200 | 200 | 055 | E | LND | 0 | E | J | EJ16 | LUZ2 | I | LND |
| EJ82223 | FDS for DCS/SIS, Logics for complex functions - Unit 223 | 76d | 2010-04-28 A | 2010-08-13 A | EJ80223 | 100% | TAP [640 h] | 640,00 | EJ82223 | EJ82223 | 86C | J06A | 213 | 200 | 200 | 055 | E | LND | 0 | E | J | EJ16 | LUZ2 | I | LND |
| EJ82224 | FDS for DCS/SIS, Logics for complex functions - Unit 224 | 76d | 2010-04-28 A | 2010-08-13 A | EJ80224 FS+1d | 100% | TAP [640 h] | 640,00 | EJ82224 | EJ82224 | 86C | J06A | 214 | 200 | 200 | 055 | E | LND | 0 | E | J | EJ16 | LUZ2 | I | LND |
| EJ82220 | FDS for DCS/SIS, Logics for complex functions - Unit 220 | 73d | 2010-05-03 A | 2010-08-13 A | EJ80220 SS+10d | 100% | TAP [640 h] | 640,00 | EJ82220 | EJ82220 | 86C | J06A | 210 | 200 | 200 | 055 | E | LND | 0 | E | J | EJ16 | LUZ2 | I | LND |
| EJ84223 | FDS for DCS/SIS, Generic sequences - Unit 223 | 64d | 2010-05-25 A | 2010-08-20 A | EJ82223 FF+5d | 100% | TAP [640 h] | 640,00 | EJ84223 | EJ84223 | 86C | J06A | 213 | 200 | 200 | 055 | E | LND | 0 | E | J | EJ16 | LUZ2 | I | LND |
| EJ84221 | FDS for DCS/SIS, Generic sequences - Unit 221 | 57d | 2010-05-27 A | 2010-08-13 A | EJ82221 FF+5d | 100% | TAP [640 h] | 640,00 | EJ84221 | EJ84221 | 86C | J06A | 211 | 200 | 200 | 055 | E | LND | 0 | E | J | EJ16 | LUZ2 | I | LND |
| EJ84222 | FDS for DCS/SIS, Generic sequences - Unit 222 | 62d | 2010-05-27 A | 2010-08-20 A | EJ82222 FF+5d | 100% | TAP [640 h] | 640,00 | EJ84222 | EJ84222 | 86C | J06A | 212 | 200 | 200 | 055 | E | LND | 0 | E | J | EJ16 | LUZ2 | I | LND |
| EJ84224 | FDS for DCS/SIS, Generic sequences - Unit 224 | 62d | 2010-05-27 A | 2010-08-20 A | EJ82224 FF+5d | 100% | TAP [640 h] | 640,00 | EJ84224 | EJ84224 | 86C | J06A | 214 | 200 | 200 | 055 | E | LND | 0 | E | J | EJ16 | LUZ2 | I | LND |
| EJ00045 | Revision - FBD Allocation | 174d | 2010-06-11 A | 2011-02-14 A | EJ00035, EJ80240 SS | 100% | TAP [1280 h] | 1280,00 | EJ00045 | EJ00045 | 86C | J06A | 400 | 200 | 200 | 055 | E | LND | 0 | E | J | EJ16 | LUZ2 | I | LND |
| EJ80240 | FBD Assignment for Interface PU's | 98d | 2010-06-11 A | 2010-10-26 A | EJ80235 SS+30d | 100% | TAP [720 h] | 720,00 | EJ80240 | EJ80240 | 86C | J06A | 400 | 200 | 200 | 055 | E | LND | 0 | E | J | EJ16 | LUZ2 | I | LND |
| EJ00055 | Revision - FDS for DCS/SIS, Generic FBD's | 94d | 2010-10-01 A | 2011-02-14 A | EJ801201 FF, EJ80218 FS+23d | 100% | TAP [1280 h] | 1280,00 | EJ00055 | EJ00055 | 86C | J06A | 400 | 200 | 200 | 055 | E | LND | 0 | E | J | EJ16 | LUZ2 | I | LND |
| EJ00060 | Revision - FDS for DCS/SIS, Logics for complex functions | 94d | 2010-10-01 A | 2011-02-14 A | EJ00055 FF, EJ801201 FF, EJ82218 FS+13d | 100% | TAP [1280 h] | 1280,00 | EJ00060 | EJ00060 | 86C | J06A | 400 | 200 | 200 | 055 | E | LND | 0 | E | J | EJ16 | LUZ2 | I | LND |
| EJ00065 | Revision - FDS for DCS/SIS, Generic Sequences | 94d | 2010-10-01 A | 2011-02-14 A | EJ801201 FF, EJ00060 FF | 100% | TAP [1280 h] | 1280,00 | EJ00065 | EJ00065 | 86C | J06A | 400 | 200 | 200 | 055 | E | LND | 0 | E | J | EJ16 | LUZ2 | I | LND |
| EJ00050 | Revision - DCS/SIS-I/O-Assignment | 89d | 2010-10-08 A | 2011-02-14 A | EJ801201 FF, EJ00040, EJ00045 FF | 100% | TAP [1280 h] | 1280,00 | EJ00050 | EJ00050 | 86C | J06A | 400 | 200 | 200 | 055 | E | LND | 0 | E | J | EJ16 | LUZ2 | I | LND |
| EJ00070 | Revision - Final Preparation Graphics (Process, PU's, Plant Util., Aut.Syst.) | 88d | 2010-10-11 A | 2011-02-14 A | EJ801201 FF, EJ00060 FF, EJ85235 | 100% | TAP [320 h] | 320,00 | EJ00070 | EJ00070 | 86C | J06A | 400 | 200 | 200 | 055 | E | LND | 0 | E | J | EJ16 | LUZ2 | I | LND |

| ID | WBS | Activity | Type | Duration | Start | Finish | Predecessors | Complete | UDF_Actictity Name (Russia) | UDF_SAVE ACTID | UDF_SAVE ACT ID | Department | Inquiry/Order No | PMT-Phase | PMT-Respons. | Zeigen/n. Zeigen | WBS Phase | WBS Discipline | IMS | UPT | WBS Type of Work | Type of Work | Constr. Area | PMT-Area | PMT-Schedule Org | PMT-Discipline | PMT-Doc. Type | WBS Objects |
| --- | --- | --- | --- | --- | --- | --- | --- | --- | --- | --- | --- | --- | --- | --- | --- | --- | --- | --- | --- | --- | --- | --- | --- | --- | --- | --- | --- | --- |
|  | NO WBS Objects | **No WBS Objects** |  |  | 2007-12-10 | 2011-04-11 |  |  |  |  |  |  |  |  |  |  |  |  |  |  |  |  |  |  |  |  |  |  |
|  | P | **P Process** |  |  |  |  |  |  |  |  |  |  |  |  |  |  |  |  |  |  |  |  |  |  |  |  |  |  |
|  | B | **B Mechanical - Stationary Equipment** |  |  | 2007-12-10 | 2010-12-23 |  |  |  |  |  |  |  |  |  |  |  |  |  |  |  |  |  |  |  |  |  |  |
| E3B100 |  | Mechanical Equipment Design | level of effort | 762d | 2007-12-10 A | 2010-12-23 A | F1640 SS, F3330 SS, F1540 SS, F1660 SS | 100% | Чертежи KM Конструкционная сталь | E3B100 | E3B100 | 007 | PP | E | LND | M1 | E | B | 1 | LND |  |  |  |  |  |  |  |  |
|  | R | **R Piping** |  |  | 2007-12-10 | 2011-04-11 |  |  |  |  |  |  |  |  |  |  |  |  |  |  |  |  |  |  |  |  |  |  |
| E3R100 |  | Plant & Piping Design | level of effort | 837d | 2007-12-10 A | 2011-04-11 A | F1000 SS, F1810 SS, F1750 SS | 100% | Проектирование комплекса и трубопроводов | E3R100 | E3R100 | 873 |  | E | LND | M1 | E | R | PL | LND | ER00 |  |  |  |  |  |  |  |
| M3R100 |  | Design Review 30% (Part I + II) | level of effort | 57d | 2008-09-29 A | 2008-12-19 A | F3060 SS | 100% | Рассмотрение проекта 30% (Часть I + II) | M3R100 | M3R100 | 007 |  | E | LND | M1 | E | R | E | LND |  |  |  |  |  |  |  |  |
| A1010110 |  | Design Review 60% | level of effort | 22d | 2009-10-19 A | 2009-11-17 A | F4035 SS | 100% | Рассмотрение проекта 60% | A1010110 | A1010110 | 007 |  | E | LND | M1 | E | R | 2 | LND |  |  |  |  |  |  |  |  |
| M3R120 |  | Design Review 90% | level of effort | 53d | 2010-04-26 A | 2010-07-09 A | F9250 SS | 100% | Рассмотрение проекта 90% | M3R120 | M3R120 | 007 |  | E | LND | M1 | E | R | 3 | LND |  |  |  |  |  |  |  |  |
|  | J | **J Instrumentation** |  |  |  |  |  |  |  |  |  |  |  |  |  |  |  |  |  |  |  |  |  |  |  |  |  |  |
|  | S | **S Safety & Environment** |  |  | 2007-12-28 | 2011-03-31 |  |  |  |  |  |  |  |  |  |  |  |  |  |  |  |  |  |  |  |  |  |  |
| E3S100 |  | Safety Design | level of effort | 819d | 2007-12-28 A | 2011-03-31 A | F1040 SS | 100% | Проектирование безопасности | E3S100 | E3S100 | 871 |  | E | LND | M1 | E | S | 1 | LND | 0000 |  |  |  |  |  |  |  |
|  | P | **Procurement (EPC Contractor)** |  |  | 2007-12-10 | 2013-06-11 |  |  |  |  |  |  |  |  |  |  |  |  |  |  |  |  |  |  |  |  |  |  |
|  | 00 | **00 Construction Areas - General** |  |  | 2007-12-10 | 2013-06-11 |  |  |  |  |  |  |  |  |  |  |  |  |  |  |  |  |  |  |  |  |  |  |
|  | LUZ2 | **LUZ2 General ( )** |  |  | 2007-12-20 | 2013-06-11 |  |  |  |  |  |  |  |  |  |  |  |  |  |  |  |  |  |  |  |  |  |  |
|  | C | **C Civil** |  |  | 2009-08-10 | 2011-08-10 |  |  |  |  |  |  |  |  |  |  |  |  |  |  |  |  |  |  |  |  |  |  |
| P3C01A |  | C01 Piling/Excavation Subcontract - Tender issued | milestone | 0d | 2009-08-10 A | 2009-08-10 A | P3C00C SF+20d, P3C00B FF+63d | 100% |  | P3C01A | P3C01A | 860 | 2MD6950 | P | LND | 0 | P | C | E | LND | PM11 | C01 | 00 | 200 | 200 | 400 | DEV | LUZ2 |
| P3C01H |  | C01 Piling/Excavation Subcontract - Bid preparation |  | 5d | 2009-08-11 A | 2009-08-17 A | P3C01A | 100% |  | P3C01H | P3C01H | 860 | 2MD6950 | P | LND | 0 | P | C | E | LND | PM11 | C01 | 00 | 200 | 200 | 400 | DEV | LUZ2 |
| P3C01C |  | C01 Piling/Excavation Subcontract - Eval./Negotiation |  | 4d | 2009-08-18 A | 2009-08-21 A | P3C01H | 100% |  | P3C01C | P3C01C | 860 | 2MD6950 | P | LND | 0 | P | C | E | LND | PM11 | C01 | 00 | 200 | 200 | 400 | DEV | LUZ2 |
| P3C02H |  | C02 Civil & Construction Subcontract - Bid preparation |  | 30d | 2009-08-18 A | 2009-09-28 A | P3C01A | 100% |  | P3C02H | P3C02H | 860 | 2MD6870 | P | CC | 0 | P | C | E | LND | PM11 | C02A | 00 | 200 | 200 | 400 | DEV | LUZ2 |
| P3C01H1 |  | C01 Piling/Excavation Subcontract - Preparation of rev. Bid's |  | 12d | 2009-08-24 A | 2009-09-08 A | P3C01C | 100% |  | P3C01H1 | P3C01H1 | 860 | 2MD6950 | P | LND | 0 | P | C | E | LND | PM11 | C01 | 00 | 200 | 200 | 400 | DEV | LUZ2 |
| P3C01C1 |  | C01 Piling/Excavation Subcontract - Final negotiations |  | 13d | 2009-09-09 A | 2009-09-25 A | P3C01H1 | 100% |  | P3C01C1 | P3C01C1 | 860 | 2MD6950 | P | LND | 0 | P | C | E | LND | PM11 | C01 | 00 | 200 | 200 | 400 | DEV | LUZ2 |
| P3C01D |  | C01 Piling/Excavation Subcontract - Contract award CA31 (downstream) | milestone | 0d | 2009-09-25 A | 2009-09-25 A | P3C01C1 | 100% |  | P3C01D | P3C01D | 860 | 2MD6950 | P | LND | 0 | P | C | E | LND | PM11 | C01 | 00 | 200 | 200 | 400 | DEV | LUZ2 |
| P3C02C |  | C02 Civil & Construction Subcontractt - Evaluation finished |  | 32d | 2009-10-01 A | 2009-11-13 A | P3C02H FS+38d | 100% |  | P3C02C | P3C02C | 860 | 2MD6870 | P | LND | 0 | P | C | E | LND | PM11 | C02A | 00 | 200 | 200 | 400 | DEV | LUZ2 |
| P3C02C1 |  | C02 Civil & Construction Subcontract - Issue of Item's for clarification | milestone | 0d | 2009-11-17 A | 2009-11-17 A | P3C02C FF+2d | 100% |  | P3C02C1 | P3C02C1 | 860 | 2MD6870 | P | LND | 0 | P | C | E | LND | PM11 | C02A | 00 | 200 | 200 | 400 | DEV | LUZ2 |
| A1010230 |  | C02 Civil Subcontract - Bid submission |  | 8d | 2009-11-19 A | 2009-11-30 A | P3C01A | 100% |  | A1010230 | A1010230 | 860 | 2MD6870 | P | CC | 0 | P | C | ci | LND | PM11 | C02B | 00 | 200 | 200 | 400 | DEV | LUZ2 |
| P3C02CA |  | C02 Civil & Construction Subcontract - Clarification Meetings |  | 2d | 2009-11-23 A | 2009-11-24 A | P3C02C SS | 100% |  | P3C02CA | P3C02CA | 860 | 2MD6870 | P | LND | 0 | P | C | E | LND | PM11 | C02A | 00 | 200 | 200 | 400 | DEV | LUZ2 |
| P3C02CC |  | C02 Civil & Construction Subcontract - Preparation for Clarification |  | 7d | 2009-11-26 A | 2009-12-04 A | P3C02CA FS+1d, P3C02C1 | 100% |  | P3C02CC | P3C02CC | 860 | 2MD6870 | P | CC | 0 | P | C | E | LND | PM11 | C02A | 00 | 200 | 200 | 400 | DEV | LUZ2 |
| A1010140 |  | C02 Civil Subcontract - Evaluation |  | 4d | 2009-12-01 A | 2009-12-04 A | P3C02H FS+30d, A1010230 | 100% |  | A1010140 | A1010140 | 860 | 2MD6870 | P | LND | 0 | P | C | ci | LND | PM11 | C02B | 00 | 200 | 200 | 400 | DEV | LUZ2 |
| P3C02CB |  | C02 Civil & Construction Subcontract - Detailed Clarification Meetings |  | 5d | 2009-12-07 A | 2009-12-11 A | P3C02CA FS+8d | 100% |  | P3C02CB | P3C02CB | 860 | 2MD6870 | P | LND | 0 | P | C | E | LND | PM11 | C02A | 00 | 200 | 200 | 400 | DEV | LUZ2 |
| P3C02CD |  | C02 Civil & Construction Subcontract - Preparation of rev. Bid's |  | 7d | 2009-12-14 A | 2009-12-22 A | P3C02CB | 100% |  | P3C02CD | P3C02CD | 860 | 2MD6870 | P | CC | 0 | P | C | E | LND | PM11 | C02A | 00 | 200 | 200 | 400 | DEV | LUZ2 |
| A1010141 |  | C02 Civil Subcontract - Issue of Item's for clarification | milestone | 0d | 2009-12-16 A | 2009-12-16 A | A1010140 FF+8d | 100% |  | A1010141 | A1010141 | 860 | 2MD6870 | P | LND | 0 | P | C | ci | LND | PM11 | C02B | 00 | 200 | 200 | 400 | DEV | LUZ2 |
| P3C02CE |  | C02 Civil & Construction Subcontract - Evaluation of rev. Bid's |  | 5d | 2010-01-04 A | 2010-01-08 A | P3C02CD FS+4d | 100% |  | P3C02CE | P3C02CE | 860 | 2MD6870 | P | LND | 0 | P | C | E | LND | PM11 | C02A | 00 | 200 | 200 | 400 | DEV | LUZ2 |
| A1010170 |  | C02 Civil Subcontract - Bid Clarification Meetings |  | 10d | 2010-01-11 A | 2010-01-22 A | A1010140 SS, P3C02CE | 100% |  | A1010170 | A1010170 | 860 | 2MD6870 | P | LND | 0 | P | C | ci | LND | PM11 | C02B | 00 | 200 | 200 | 400 | DEV | LUZ2 |
| A1010180 |  | C02 Civil Subcontract - Bid Clarification Meetings / Negotiations |  | 391d | 2010-02-01 A | 2011-08-10 A | A1010170 | 100% |  | A1010180 | A1010180 | 860 | 2MD6870 | P | PMT | 0 | P | C | ci | LND | PM11 | C02 | 00 | 200 | 200 | 400 | DEV | LUZ2 |
| P3N012C |  | N01 Structural Steel Erection - Bid Clarification Meetings / Negotiations |  | 209d | 2010-02-01 A | 2010-11-25 A | P3N01C SS | 100% |  | P3N012C | P3N012C | 860 | N01 | P | PMT | 0 | P | C | ci | LND | PM11 | N012 | 00 | 200 | 200 | 400 | DEV | LUZ2 |
| P3C01D1 |  | C01 Piling/Excavation Subcontract - Contract award (upstream) - MS11 | milestone | 0d | 2010-02-12 A | 2010-02-12 A | P3C01D | 100% |  | P3C01D1 | P3C01D1 | 860 | 2MD6950 | P | LND | C9 | P | C | E | LND | PM11 | C01 | 00 | 200 | 200 | 400 | DEV | LUZ2 |
| P3C02D1 |  | C02 Civil Subcontract - Contract award (Foundation works) - MS11 | milestone | 0d | 2010-04-23 A | 2010-04-23 A | A1010141, A1010180 SF, P3C02CC, P3C02CE, E3E1135 | 100% |  | P3C02D1 | P3C02D1 | 860 | 2MD6870 | P | LND | C9 | P | C | ci | LND | PM11 | C02 | 00 | 200 | 200 | 400 | DEV | LUZ2 |
| P3C02D2 |  | C02 Civil Subcontract - Contract award (remain. Civil works Part I (concrete/precast works - main areas)) - MS11 | milestone | 0d | 2010-07-26 A | 2010-07-26 A | A1010180 SF, P3C02D1 FS+30d | 100% |  | P3C02D2 | P3C02D2 | 860 | 2MD6870 | P | LND | C9 | P | C | ci | LND | PM11 | C02 | 00 | 200 | 200 | 400 | DEV | LUZ2 |
| P3N012D |  | N01 Structural Steel Erection - PO issued Chelyabinsk | milestone | 0d | 2010-11-25 A | 2010-11-25 A | P3N012C FF | 100% |  | P3N012D | P3N012D | 860 | N01 | P | PMT | C7 | P | C | ci | LND | PM11 | N012 | 00 | 200 | 200 | 400 | DEV | LUZ2 |
| P3C02D3 |  | C02 Civil Subcontract - Contract award (remain. Civil works Part II (concrete/precast works - minor areas)) - MS11 | milestone | 0d | 2010-12-20 A | 2010-12-20 A | P3C02D2 FF+92d, A1010180 FF | 100% |  | P3C02D3 | P3C02D3 | 860 | 2MD6870 | P | LND | C9 | P | C | ci | LND | PM11 | C02 | 00 | 200 | 200 | 400 | DEV | LUZ2 |
| P3C02D4 |  | C02 Civil Subcontract - Contract award (remain. Civil works Part III (U/G / precast manholes/CB) | milestone | 0d | 2011-08-10 A | 2011-08-10 A | A1010180 FF, P3C02D3 FF | 100% |  | P3C02D4 | P3C02D4 | 860 | 2MD6870 | P | LND | C9 | P | C | ci | LND | PM11 | C02 | 00 | 200 | 200 | 400 | DEV | LUZ2 |

| ID | WBS | Activity | Type | Duration | Start | Finish | Predecessors | Complete | Remaining | Total float | Free float | Calendar | Cost | Actual cost | UDF_SAVE ACTID | UDF_SAVE ACT ID | Department | Type of Work | Constr. Area | Inquiry/Order No | PMT-Area | PMT-Schedule Org | PMT-Discipline | PMT-Phase | PMT-Doc. Type | PMT-Respons. | Zeigen/n. Zeigen | WBS Phase | WBS Discipline | WBS Type of Work | WBS Objects | IMS | UPT | Pro Unit/DocCode | PMT-Stage |
| --- | --- | --- | --- | --- | --- | --- | --- | --- | --- | --- | --- | --- | --- | --- | --- | --- | --- | --- | --- | --- | --- | --- | --- | --- | --- | --- | --- | --- | --- | --- | --- | --- | --- | --- | --- |
|  | N | **N Structural Steel** |  |  | 2009-06-15 | 2010-11-30 |  |  |  |  |  |  |  |  |  |  |  |  |  |  |  |  |  |  |  |  |  |  |  |  |  |  |  |  |  |
| P3N01A |  | N01 Structural Steel Fab - Prepare/Issue RFQ |  | 9d | 2009-06-15 A | 2009-06-25 A | EN151110, E3N0110, EN151303 | 100% |  |  |  |  |  |  | P3N01A | P3N01A | 860 | N01 | 00 | 2M00020 | 200 | 200 | 400 | P | DEV | LND | 0 | P | N | PM11 | LUZ2 | E | LND |  |  |
| P3N01B |  | N01 Structural Steel Fab - RFQ issued | milestone | 0d | 2009-06-25 A | 2009-06-25 A | P3N01A FF, EN15N0340 | 100% |  |  |  |  |  |  | P3N01B | P3N01B | 860 | N01 | 00 | 2M00020 | 200 | 200 | 400 | P | DEV | LND | 0 | P | N | PM11 | LUZ2 | SS | LND |  |  |
| P3N01C |  | N01 Structural Steel Fab - Eval./Negotiation |  | 171d | 2009-10-22 A | 2010-06-30 A | E3N0120 FF | 100% |  |  |  |  |  |  | P3N01C | P3N01C | 860 | N01 | 00 | 2M00020 | 200 | 200 | 400 | P |  | LND | 0 | P | N | PM12 | LUZ2 | SS | LND |  |  |
| P3N01D |  | N01 Structural Steel Fab - PO issued (Cheljabinsk) | milestone | 0d | 2010-06-30 A | 2010-06-30 A | E3N0130 FF, EN24510205, P3N01C | 100% |  |  |  |  |  |  | P3N01D | P3N01D | 860 | N01 | 00 | 2M00020 | 200 | 200 | 400 | P |  | LND | C9 | P | N | PN23 | LUZ2 | SS | LND |  |  |
| P3N01L |  | N01 Structural Steel Fab - Lead Time/Fabrication 1st Goods |  | 148d | 2010-07-01 A | 2010-11-25 A | P3N01D | 100% |  |  |  | TB26 - 2 - Manuf and Delivy |  |  | P3N01L | P3N01L | 860 | N01 | 00 | 2M00020 | 200 | 200 | 400 | P | DEL | LND | 0 | P | N | PM16 | LUZ2 | SS | LND |  |  |
| P3N01X |  | N01 Structural Steel Fab - Final Inspection | milestone | 0d | 2010-10-30 A | 2010-10-30 A | P3N01L FF-10d | 100% |  |  |  | TB26 - 2 - Manuf and Delivy |  |  | P3N01X | P3N01X | 860 | N01 | 00 | 2M00020 | 200 | 200 | 400 | P |  | LND | 0 | P | N | PM17 | LUZ2 | SS | LND |  |  |
| P3N01M |  | N01 Structural Steel Fab - Goods deliv. FCA/FOB | milestone | 0d | 2010-11-25 A | 2010-11-25 A | P3N01L FF, P3N01X FF | 100% |  |  |  | TB26 - 2 - Manuf and Delivy |  |  | P3N01M | P3N01M | 860 | N01 | 00 | 2M00020 | 200 | 200 | 400 | P |  | LND | 0 | P | N | PM18 | LUZ2 | SS | LND |  |  |
| P3N01N |  | N01 Structural Steel Fab - Transport to Site |  | 5d | 2010-11-26 A | 2010-11-30 A | P3N01M | 100% |  |  |  | TB26 - 2 - Manuf and Delivy |  |  | P3N01N | P3N01N | 860 | N01 | 00 | 2M00020 | 200 | 200 | 400 | P |  | LND | 0 | P | N | PM18 | LUZ2 | SS | LND |  |  |
|  | H | **H HVAC** |  |  | 2009-07-20 | 2011-11-27 |  |  |  |  |  |  |  |  |  |  |  |  |  |  |  |  |  |  |  |  |  |  |  |  |  |  |  |  |  |
| P3H01A |  | H01 HVAC Equipm. - Prepare/Issue RFQ |  | 21d | 2009-07-20 A | 2009-08-17 A | E3H0150 SS+60d, E3H0115 FS+10d, E3H0110 FS+10d | 100% |  |  |  |  |  |  | P3H01A | P3H01A | 860 | H01 | 00 | H01 | 000 | 200 | 400 | P | DEV | LND | 0 | P | H | PH11 | LUZ2 | P | LND |  |  |
| P3H01B |  | H01 HVAC Equipm. - RFQ issued (Part of Construction Tender) | milestone | 0d | 2009-08-17 A | 2009-08-17 A | P3H01A FF | 100% |  |  |  |  |  |  | P3H01B | P3H01B | 860 | H01 | 00 | H01 | 000 | 200 | 400 | P | DEV | PMT | 0 | P | H | PH11 | LUZ2 | P | LND |  |  |
| P3H01D |  | H01 HVAC Equipm. - PO issued | milestone | 0d | 2010-12-20 A | 2010-12-20 A | EH201736, EH201770, EH203130, EH203120, EH203140, P3C02D2 FF, EH201110, EH201610, EH201740, EH201222, EH201720, EH201321, EH201221, EH201710, EH203110, E3H0120 FF, EH201322 | 100% |  |  |  |  |  |  | P3H01D | P3H01D | 860 | H01 | 00 | H01 | 000 | 200 | 400 | P |  | PMT | L2 | P | H | PH13 | LUZ2 | P | LND |  |  |
| P3H01E |  | H01 HVAC Eq. - Vendor Procurem.+Engineering |  | 132d | 2010-12-21 A | 2011-05-05 A | P3H01D | 100% |  |  |  | TB26 - 2 - Manuf and Delivy |  |  | P3H01E | P3H01E | 860 | H01 | 00 | H01 | 000 | 200 | 400 | P | DEV | SC | 0 | P | H | PH15 | LUZ2 | P | LND |  |  |
| P3H01L |  | H01 HVAC Equipm. - Vendor Fabrication |  | 248d | 2010-12-21 A | 2011-08-29 A | P3H01E SS | 100% |  |  |  | TB26 - 2 - Manuf and Delivy |  |  | P3H01L | P3H01L | 860 | H01 | 00 | H01 | 000 | 200 | 400 | P | DEV | SC | L2 | P | H | PH16 | LUZ2 | P | LND |  |  |
| P3H01P |  | H01 HVAC Equipm. - Transport to Site |  | 243d | 2011-03-29 A | 2011-11-27 | P3H01L SS+95d, IMS-P-000100 (other project) FF |  | 88d | -132d | 553.5d | TB26 - 2 - Manuf and Delivy |  |  | P3H01P | P3H01P | 860 | H01 | 00 | H01 | 000 | 200 | 400 | P |  | SC | L2 | P | H | PH18 | LUZ2 | hva_as | LND |  |  |
|  | U | **U Package Units** |  |  | 2008-01-16 | 2011-11-04 |  |  |  |  |  |  |  |  |  |  |  |  |  |  |  |  |  |  |  |  |  |  |  |  |  |  |  |  |  |
| P3U12A |  | PU12 Propyl.Recov.Unit - Prepare/Issue RFQ |  | 11d | 2008-01-16 A | 2008-01-30 A | F1660 SS, F1540 SS | 100% |  |  |  |  |  |  | P3U12A | P3U12A | 860 | PU12 | 00 | 2KB4240 | 200 | 200 | 400 | P | DEV | LND | C2 | P | U | PU91 | LUZ2 | E | LND | DC | 3A |
| F8320 |  | PU12 Propyl.Recov.Unit - Issue RFQ to PMT review | milestone | 0d | 2008-01-31 A | 2008-01-31 A | P3U12B FF | 100% |  |  |  |  |  |  | F8320 | F8320 | 860 | PU12 | 00 | 2KB4240 | 200 | 200 | 400 | P |  | LND | C2 | P | U | PU91 | LUZ2 | 1 | LND |  | 3A |
| F8330 |  | PU12 Propyl.Recov.Unit - PMT approve RFQ Package |  | 7d | 2008-01-31 A | 2008-02-08 A | F8320 | 100% |  |  |  |  |  |  | F8330 | F8330 | 860 | PU12 | 00 | 2KB4240 | 200 | 200 | 400 | P |  | PMT | C2 | P | U | PU91 | LUZ2 | 1 | LND |  | 3A |
| P3U02A |  | PU02 Add. Feed Syst. - Prepare/Issue RFQ |  | 31d | 2008-02-01 A | 2008-03-14 A | F1540 SS, F1660 SS+20d | 100% |  |  |  |  |  |  | P3U02A | P3U02A | 860 | PU02 | 00 | 2DC9820 | 200 | 200 | 400 | P | DEV | LND | C2 | P | U | PU21 | LUZ2 | P | LND | DC | 3A |
| P3U12B |  | PU12 Propyl.Recov.Unit - RFQ issued to bidders | milestone | 0d | 2008-02-09 A | 2008-02-09 A | P3U12A FF | 100% |  |  |  |  | 339,665.35 | 339,665.35 | P3U12B | P3U12B | 860 | PU12 | 00 | 2KB4240 | 200 | 200 | 400 | P |  | LND | C2 | P | U | PU91 | LUZ2 | E | LND | DC | 3A |
| F8210 |  | PU12 Propyl.Recov.Unit - Vendor Bid Preparation |  | 61d | 2008-02-11 A | 2008-05-08 A | P3U12B | 100% |  |  |  |  |  |  | F8210 | F8210 | 860 | PU12 | 00 | 2KB4240 | 200 | 200 | 400 | P |  | LND | C2 | P | U | PU92 | LUZ2 | 1 | LND | DC | 3A |
| F8130 |  | PU02 Add. Feed Syst. - PMT approve RFQ |  | 5d | 2008-03-10 A | 2008-03-14 A | F8120 | 100% |  |  |  |  |  |  | F8130 | F8130 | 860 | PU02 | 00 | 2DC9820 | 200 | 200 | 400 | P |  | PMT | C2 | P | U | PU21 | LUZ2 | 1 | LND |  | 3A |
| F8120 |  | PU02 Add. Feed Syst. - Issue RFQ to PMT | milestone | 0d | 2008-03-11 A | 2008-03-11 A | P3U02A FF | 100% |  |  |  |  |  |  | F8120 | F8120 | 860 | PU02 | 00 | 2DC9820 | 200 | 200 | 400 | P |  | LND | C2 | P | U | PU21 | LUZ2 | 1 | LND |  | 3A |
| P3U02B |  | PU02 Add. Feed Syst. - RFQ issued to bidders | milestone | 0d | 2008-03-15 A | 2008-03-15 A | P3U02A FF | 100% |  |  |  |  | 282,004.1 | 282,004.1 | P3U02B | P3U02B | 860 | PU02 | 00 | 2DC9820 | 200 | 200 | 400 | P |  | LND | C2 | P | U | PU21 | LUZ2 | P | LND | DC | 3A |
| F8010 |  | PU02 Add. Feed Syst. - Vendor Bid Preparation |  | 19d | 2008-03-17 A | 2008-04-14 A | P3U02B FS+10d | 100% |  |  |  |  |  |  | F8010 | F8010 | 860 | PU02 | 00 | 2DC9820 | 200 | 200 | 400 | P |  | LND | C2 | P | U | PU21 | LUZ2 | 1 | LND | DC | 3A |
| P3U15A |  | PU15 Reactor Seal Oil Pack - Prepare/Issue RFQ |  | 4d | 2008-04-01 A | 2008-04-04 A | E3U1510 | 100% |  |  |  |  |  |  | P3U15A | P3U15A | 860 | PU15 | 00 | 2DC8910 | 200 | 200 | 400 | P | DEV | LND | 0 | P | U | PU91 | LUZ2 | E | LND |  |  |
| P3U15B |  | PU15 Reactor Seal Oil Pack - RFQ issued | milestone | 0d | 2008-04-05 A | 2008-04-05 A | P3U15A FF | 100% |  |  |  |  | 38,350 | 38,350 | P3U15B | P3U15B | 860 | PU15 | 00 | 2DC8910 | 200 | 200 | 400 | P | DEV | LND | 0 | P | U | PU91 | LUZ2 | E | LND |  |  |
| F3440 |  | Decision Gate (Purchaising Strategie) | milestone | 0d | 2008-04-18 A | 2008-04-18 A | F3710 FF | 100% |  |  |  |  |  |  | F3440 | F3440 | 860 |  | 00 |  | 200 | 200 |  | P |  |  |  | P | U | 0000 | LUZ2 | PI | LND | 90 |  |
| P3U22A |  | PU22 Vacuum System - Prepare/Issue RFQ |  | 4d | 2008-04-30 A | 2008-05-06 A | E3U2210 | 100% |  |  |  |  |  |  | P3U22A | P3U22A | 860 | PU22 | 00 | 2DC9170 | 200 | 200 | 400 | P | DEV | LND | 0 | P | U | PU91 | LUZ2 | E | LND |  |  |
| F8140 |  | PU02 Add. Feed Syst. - Vendor Bid for INEOS Rev | milestone | 0d | 2008-05-02 A | 2008-05-02 A | F8060 FS-1d, F8130 | 100% |  |  |  |  |  |  | F8140 | F8140 | 860 | PU02 | 00 | 2DC9820 | 200 | 200 | 400 | P |  | LND | C2 | P | U | PU22 | LUZ2 | 1 | LND |  | 3A |
| P3U02C |  | PU02 Add. Feed Syst. - Eval./Negotiation |  | 123d | 2008-05-05 A | 2008-10-24 A | F8060 FS+10d | 100% |  |  |  |  |  |  | P3U02C | P3U02C | 860 | PU02 | 00 | 2DC9820 | 200 | 200 | 400 | P |  | LND | C2 | P | U | PU22 | LUZ2 | P | LND | DC | 3A |
| P3U22B |  | PU22 Vacuum System - RFQ issued | milestone | 0d | 2008-05-07 A | 2008-05-07 A | P3U22A FF | 100% |  |  |  |  | 43,885 | 43,885 | P3U22B | P3U22B | 860 | PU22 | 00 | 2DC9170 | 200 | 200 | 400 | P | DEV | LND | 0 | P | U | PU91 | LUZ2 | E | LND |  |  |
| F8340 |  | PU12 Prop.Rec.Unit - Vendor Bid for INEOS Review | milestone | 0d | 2008-05-09 A | 2008-05-09 A | F8210, F8330 | 100% |  |  |  |  |  |  | F8340 | F8340 | 860 | PU12 | 00 | 2KB4240 | 200 | 200 | 400 | P |  | LND | C2 | P | U | PU92 | LUZ2 | 1 | LND |  | 3A |
| P3U06A |  | PU06 Bagging System - Prepare/Issue RFQ |  | 4d | 2008-05-16 A | 2008-05-21 A | E3U0610 | 100% |  |  |  |  |  |  | P3U06A | P3U06A | 860 | PU06 | 00 | 2DC9010 | 200 | 200 | 400 | P | DEV | LND | C2 | P | U | PU31 | LUZ2 | E | LND | DC |  |
| P3U12C |  | PU12 Propyl.Recov.Unit - Eval./Negotiation |  | 399d | 2008-05-19 A | 2009-12-16 A | F8260 | 100% |  |  |  |  |  |  | P3U12C | P3U12C | 860 | PU12 | 00 | 2KB4240 | 200 | 200 | 400 | P |  | LND | C2 | P | U | PU92 | LUZ2 | E | LND | DC | 3A |
| F10220 |  | PU06 Bagging System - PMT approve RFQ |  | 4d | 2008-05-22 A | 2008-05-27 A | P3U07A, P3U06A | 100% |  |  |  |  |  |  | F10220 | F10220 | 860 | PU06 | 00 | 2DC9010 | 200 | 200 | 400 | P |  | PMT | C2 | P | U | PU31 | LUZ2 | 1 | LND | DC |  |
| P3U10A |  | PU10 Convey. Syst. - Prepare/Issue RFQ |  | 3d | 2008-05-23 A | 2008-05-27 A | E3U1010 FF | 100% |  |  |  |  |  |  | P3U10A | P3U10A | 860 | PU10 | 00 | 2DC8990 | 200 | 200 | 400 | P | DEV | LND | C2 | P | U | PU11 | LUZ2 | E | LND | DC |  |
| P3U07A |  | PU07 Packaging Syst. - Prepare/Issue RFQ |  | 4d | 2008-05-26 A | 2008-05-29 A | E3U0710 | 100% |  |  |  |  |  |  | P3U07A | P3U07A | 860 | PU07 | 00 | 2DC9020 | 200 | 200 | 400 | P | DEV | LND | C2 | P | U | PU31 | LUZ2 | E | LND | DC |  |
| F10430 |  | PU10 Convey. Syst. - PMT approve RFQ |  | 5d | 2008-05-28 A | 2008-06-03 A | P3U10A | 100% |  |  |  |  |  |  | F10430 | F10430 | 860 | PU10 | 00 | 2DC8990 | 200 | 200 | 400 | P |  | PMT | C2 | P | U | PU11 | LUZ2 | 1 | LND | DC |  |
| P3U06B |  | PU06 Bagging System - RFQ issued | milestone | 0d | 2008-05-28 A | 2008-05-28 A | F10220 FF | 100% |  |  |  |  | 54,442.7 | 54,442.7 | P3U06B | P3U06B | 860 | PU06 | 00 | 2DC9010 | 200 | 200 | 400 | P | DEV | LND | C2 | P | U | PU31 | LUZ2 | E | LND | DC |  |
| P3U07B |  | PU07 Packaging Syst. - RFQ issued | milestone | 0d | 2008-05-30 A | 2008-05-30 A | F10220 FF | 100% |  |  |  |  | 96,237.5 | 96,237.5 | P3U07B | P3U07B | 860 | PU07 | 00 | 2DC9020 | 200 | 200 | 400 | P | DEV | LND | C2 | P | U | PU31 | LUZ2 | E | LND | DC |  |
| P3U10B |  | PU10 Convey. Syst. - RFQ issued | milestone | 0d | 2008-06-04 A | 2008-06-04 A | F10430 FF | 100% |  |  |  |  | 1,039,519.1 | 1,039,519.1 | P3U10B | P3U10B | 860 | PU10 | 00 | 2DC8990 | 200 | 200 | 400 | P | DEV | LND | C2 | P | U | PU11 | LUZ2 | E | LND | DC |  |
| F8190 |  | PU02 Add. Feed Syst. - Bid tab Client appr./VA |  | 61d | 2008-07-11 A | 2008-10-06 A | P3U02C FF, E3U0230 | 100% |  |  |  |  |  |  | F8190 | F8190 | 860 | PU02 | 00 | 2DC9820 | 200 | 200 | 400 | P |  | PMT | C2 | P | U | PU22 | LUZ2 | 1 | LND |  | 3A |
| P3U10C |  | PU10 Convey. Syst. - Eval./Negotiation |  | 45d | 2008-07-14 A | 2008-09-12 A | E3U1020 FF | 100% |  |  |  |  |  |  | P3U10C | P3U10C | 860 | PU10 | 00 | 2DC8990 | 200 | 200 | 400 | P |  | LND | C2 | P | U | PU12 | LUZ2 | E | LND | DC |  |
| F8390 |  | PU12 Propyl.Recov.Unit - Bid tab Client appr./VA |  | 342d | 2008-07-21 A | 2009-11-30 A | E3U1230 | 100% |  |  |  |  |  |  | F8390 | F8390 | 860 | PU12 | 00 | 2KB4240 | 200 | 200 | 400 | P |  | PMT | C2 | P | U | PU92 | LUZ2 | E | PMT |  | 3A |
| P3U07C |  | PU07 Packaging Syst. - Eval./Negotiation |  | 354d | 2008-07-22 A | 2009-12-17 A | P3U07B, E3U0720 FF | 100% |  |  |  |  |  |  | P3U07C | P3U07C | 860 | PU07 | 00 | 2DC9020 | 200 | 200 | 400 | P |  | LND | C2 | P | U | PU32 | LUZ2 | E | LND | DC |  |
| P3U06C |  | PU06 Bagging System - Eval./Negotiation |  | 372d | 2008-08-04 A | 2010-01-29 A | E3U0620 FF, P3U06B | 100% |  |  |  |  |  |  | P3U06C | P3U06C | 860 | PU06 | 00 | 2DC9010 | 200 | 200 | 400 | P |  | LND | C2 | P | U | PU32 | LUZ2 | E | LND | DC |  |
| F10470 |  | PU10 Convey. Syst. - Bid tab Client appr. |  | 23d | 2008-08-08 A | 2008-09-09 A | E3U1030 | 100% |  |  |  |  |  |  | F10470 | F10470 | 860 | PU10 | 00 | 2DC8990 | 200 | 200 | 400 | P |  | LND | C2 | P | U | PU12 | LUZ2 | 1 | LND | DC | 3A |
| P3U05A |  | PU05 Big Bag L. Station - Prepare/Issue RFQ |  | 3d | 2008-09-01 A | 2008-09-03 A | E3U0510 | 100% |  |  |  |  |  |  | P3U05A | P3U05A | 860 | PU05 | 00 | 2DC9640 | 200 | 200 | 400 | P | DEV | LND | 0 | P | U | PU91 | LUZ2 | E | LND |  |  |
| P3U05B |  | PU05 Big Bag L. Station - RFQ issued | milestone | 0d | 2008-09-04 A | 2008-09-04 A | P3U05A FF | 100% |  |  |  |  | 5,458.8 | 5,458.8 | P3U05B | P3U05B | 860 | PU05 | 00 | 2DC9640 | 200 | 200 | 400 | P | DEV | LND | 0 | P | U | PU91 | LUZ2 | E | LND |  |  |
| P3U10D |  | PU10 Convey. Syst. - PO issued | milestone | 0d | 2008-09-13 A | 2008-09-13 A | F10420 FF, F10470 FF, E3U1030 FF, P3U10C FF, F2920 FF | 100% |  |  |  |  | 4,158,076.4 | 4,158,076.4 | P3U10D | P3U10D | 860 | PU10 | 00 | 2DC8990 | 200 | 200 | 400 | P |  | LND | C2 | P | U | PU13 | LUZ2 | E | LND | DC | 3A |
| P3U10L |  | PU10 Convey. Syst. - Lead Time/Fabrication |  | 801d | 2008-09-13 A | 2010-11-30 A | P3U10D | 100% |  |  |  | TB26 - 2 - Manuf and Delivy |  |  | P3U10L | P3U10L | 860 | PU10 | 00 | 2DC8990 | 200 | 200 | 400 | P | DEL | LND | C2 | P | U | PU16 | LUZ2 | E | LND | DC |  |
| HPU10 |  | Conveying Syst.(PU10) PO/Fabr./Transport to Site | level of effort | 528d | 2008-09-15 A | 2010-10-22 A | P3U10L SS | 100% |  |  |  |  |  |  | HPU10 | HPU10 | 869 |  | 00 | 999 | 200 | 200 | 400 | E | DFA | LND | L2 | P | U | PU93 | LUZ2 | E | LND |  |  |
| P3U15C |  | PU15 Reactor Seal Oil Pack - Eval./Negotiation |  | 210d | 2008-10-09 A | 2009-08-14 A | P3U15B, E3U1520 FF | 100% |  |  |  |  |  |  | P3U15C | P3U15C | 860 | PU15 | 00 | 2DC8910 | 200 | 200 | 400 | P |  | LND | 0 | P | U | PU92 | LUZ2 | E | LND |  |  |
| P3U22C |  | PU22 Vacuum System - Eval./Negotiation |  | 174d | 2008-10-16 A | 2009-07-02 A | P3U22B, E3U2220 FF | 100% |  |  |  |  |  |  | P3U22C | P3U22C | 860 | PU22 | 00 | 2DC9170 | 200 | 200 | 400 | P |  | LND | 0 | P | U | PU92 | LUZ2 | E | LND |  |  |
| P3U05C |  | PU05 Big Bag L. Station - Eval./Negotiation |  | 436d | 2008-10-24 A | 2010-07-26 A | P3U05B, E3U0520 FF | 100% |  |  |  |  |  |  | P3U05C | P3U05C | 860 | PU05 | 00 | 2DC9640 | 200 | 200 | 400 | P |  | LND | 0 | P | U | PU92 | LUZ2 | E | LND |  |  |
| P3U02D |  | PU02 Add. Feed Syst. - PO issued | milestone | 0d | 2008-10-25 A | 2008-10-25 A | P3U02C FF, F8190 FF, F2920 FF | 100% |  |  |  |  | 1,128,016.4 | 1,128,016.4 | P3U02D | P3U02D | 860 | PU02 | 00 | 2DC9820 | 200 | 200 | 400 | P |  | LND | C2 | P | U | PU23 | LUZ2 | P | LND | DC | 3A |
| P3U02L |  | PU02 Add. Feed Syst. - Fabrication/Delivery |  | 698d | 2008-10-25 A | 2010-09-30 A | P3U02D | 100% |  |  |  | TB26 - 2 - Manuf and Delivy |  |  | P3U02L | P3U02L | 860 | PU02 | 00 | 2DC9820 | 200 | 200 | 400 | P | DEL | LND | C2 | P | U | PU26 | LUZ2 | E | LND | DC |  |
| HPU02 |  | Additive Syst. (PU02) PO/Fabr./Transport to Site | level of effort | 522d | 2008-10-27 A | 2010-11-25 A | P3U02L SS | 100% |  |  |  |  |  |  | HPU02 | HPU02 | 869 |  | 00 |  | 200 | 200 | 400 | E | DFA | LND | L2 | P | U | PU93 | LUZ2 | E | LND |  |  |
| P3U06F |  | PU06 Bagging System - Bid tab Client appr. |  | 152d | 2008-10-30 A | 2009-06-16 A | E3U0630 | 100% |  |  |  |  |  |  | P3U06F | P3U06F | 860 | PU06 | 00 | 2DC9010 | 200 | 200 | 400 | P |  | PMT | 0 | P | U | PU32 | LUZ2 | P | LND |  |  |
| P3U07F1 |  | PU07 Packaging Syst. - Bid tab Client appr. |  | 151.42d | 2008-10-30 A | 2009-06-16 A | E3U0730 | 100% |  |  |  |  |  |  | P3U07F1 | P3U07F1 | 860 | PU07 | 00 | 2DC9020 | 200 | 200 | 400 | P |  | PMT | 0 | P | U | PU32 | LUZ2 | P | LND |  |  |
| F3420 |  | Award Design concept conveying | milestone | 0d | 2008-11-03 A | 2008-11-03 A | F2760 | 100% |  |  |  |  |  |  | F3420 | F3420 | 860 |  | 00 |  | 200 | 200 |  | P |  |  |  | P | U | 0000 | LUZ2 | PI | LND | 90 |  |
| F2970 |  | P.O. Conveying (incl. Compressors) | milestone | 0d | 2008-11-05 A | 2008-11-05 A | P3U10D, F2830 | 100% |  |  |  |  |  |  | F2970 | F2970 | 860 |  | 00 |  | 200 | 200 |  | P |  |  |  | P | U | 0000 | LUZ2 | P | LND | 90 |  |
| F2980 |  | Fabr. & Deliv. Conveying (incl. Compressors) |  | 815d | 2008-11-05 A | 2011-02-08 A | F2970 SS, P3U10L SS, P3U10S3 FF, P3U10S1 FF | 100% |  |  |  | TB26 - 2 - Manuf and Delivy |  |  | F2980 | F2980 | 860 |  | 00 |  | 200 | 200 |  | P |  |  |  | P | U | 0000 | LUZ2 | E | LND | 90 |  |
| P3U15F |  | PU15 Reactor Seal Oil Pac - Bid tab Client appr. |  | 24d | 2008-12-01 A | 2009-01-08 A | E3U1530 | 100% |  |  |  |  |  |  | P3U15F | P3U15F | 860 | PU15 | 00 | 2DC8910 | 200 | 200 | 400 | P |  | PMT | 0 | P | U | PU92 | LUZ2 | P | LND |  |  |
| P3U22F |  | PU22 Vacuum System - Bid tab Client appr. |  | 74d | 2009-02-26 A | 2009-06-16 A | E3U2230 | 100% |  |  |  |  |  |  | P3U22F | P3U22F | 860 | PU22 | 00 | 2DC9170 | 200 | 200 | 400 | P |  | PMT | 0 | P | U | PU92 | LUZ2 | P | LND |  |  |
| HPU20 |  | PU - Remaining Engineering PO's | level of effort | 66.58d | 2009-05-15 A | 2009-08-19 A | P3U22D1, P3U15D1 FF, P3A18D FF | 100% |  |  |  |  |  |  | HPU20 | HPU20 | 869 |  | 00 |  | 200 | 200 | 400 | E | DFA | LND | L2 | P | U | PU93 | LUZ2 | E | LND |  |  |
| P3U22D1 |  | PU22 Vacuum System - PO issued (Engineering) | milestone | 0d | 2009-07-02 A | 2009-07-02 A | E3U2230 FF, F2940 FF, P3U22E, P3U22F FF, P3U22C FF | 100% |  |  |  |  |  |  | P3U22D1 | P3U22D1 | 860 | PU22 | 00 | 2DC9170 | 200 | 200 | 400 | P |  | LND | 0 | P | U | PU93 | LUZ2 | E | LND |  |  |

Notes:
- P3N01D: UDF_Actictity Name (Russia): N01 Металлоконструкции - Выпуск заказа на поставку
- P3H01D: UDF_Actictity Name (Russia): H01 Оборудование ОВКВ - Выпуск заказа на поставку
- P3H01L: UDF_Actictity Name (Russia): H01 Оборудование ОВКВ - Изготовление Поставщиком
- P3H01P: UDF_Actictity Name (Russia): H01 Оборудование ОВКВ - Транспортировка на площадку
- P3U12B: Expenses: 900A 339665
- P3U02B: Expenses: 900A 282004
- P3U15B: Expenses: 900A 38350
- P3U22B: Expenses: 900A 43885
- P3U06B: Expenses: 900A 54442.7
- P3U07B: Expenses: 900A 96237.5
- P3U10B: Expenses: 900A 1039519
- P3U05B: Expenses: 900A 5458.8
- P3U10D: Expenses: 900A 4158076
- HPU10: UDF_Actictity Name (Russia): Конвейерная система (PU10), заказ на поставку/изготовление/транспортировка на площадку
- P3U02D: P3 Activity Log Info: on Hold by Client / Expenses: 900A 1128016
- HPU02: UDF_Actictity Name (Russia): Система аддитивов (PU02), заказ на поставку/изготовление/транспортировка на площадку
- F2980: P3 Activity Log Info: 17month fab&deliv.+3month transp/custom clearanc
- HPU20: UDF_Actictity Name (Russia): Комплектные установки - Оставшиеся заказы на проектирование

| ID | Activity | Type | Duration | Start | Finish | Predecessors | Complete | Remaining | Total float | Free float | Constraint | Expected finish | Calendar | Cost | Actual cost | UDF_SAVE ACTID | UDF_SAVE ACT ID | Department | Type of Work | Constr. Area | Inquiry/Order No | PMT-Area | PMT-Schedule Org | PMT-Discipline | PMT-Phase | PMT-Respons. | Zeigen/n. Zeigen | WBS Phase | WBS Discipline | WBS Type of Work | WBS Objects | IMS | UPT | Pro Unit/DocCode | PMT-Doc. Type | UDF_CHECK BASELINE |
| --- | --- | --- | --- | --- | --- | --- | --- | --- | --- | --- | --- | --- | --- | --- | --- | --- | --- | --- | --- | --- | --- | --- | --- | --- | --- | --- | --- | --- | --- | --- | --- | --- | --- | --- | --- | --- |
| P3U15D1 | PU15 Reactor Seal Oil Pack - PO issued (Engin.) | milestone | 0d | 2009-08-12 A | 2009-08-12 A | P3U15F, P3U15C | 100% |  |  |  |  |  |  |  |  | P3U15D1 | P3U15D1 | 860 | PU15 | 00 | 2DC8910 | 200 | 200 | 400 | P | LND | 0 | P | U | PU93 | LUZ2 | E | LND |  |  |  |
| P3U02X | PU02 Add. Feed Syst. - Final Inspection |  | 5d | 2009-12-10 A | 2009-12-14 A | E3U0260 FF+10d, P3U02L FF-5d | 100% |  |  |  |  |  | TB26 - 2 - Manuf and Delivy | 1,692,024.6 | 1,692,024.6 | P3U02X | P3U02X | 860 | PU02 | 00 | 2DC9820 | 200 | 200 | 400 | P | LND | C2 | P | U | PU27 | LUZ2 | E | LND | DC |  |  |
| P3U22D2 | PU22 Vacuum System - PO issued (Equipm.) | milestone | 0d | 2009-12-16 A | 2009-12-16 A | P3U22D1 FS+118d | 100% |  |  |  |  |  |  | 175,540 | 175,540 | P3U22D2 | P3U22D2 | 860 | PU22 | 00 | 2DC9170 | 200 | 200 | 400 | P | LND | 0 | P | U | PU93 | LUZ2 | P | LND |  |  |  |
| HPU22 | Vent Coll. (PU22) PO/Fabr./Transport to Site | level of effort | 409d | 2009-12-17 A | 2011-07-27 A | P3U22L SS | 100% |  |  |  |  |  |  |  |  | HPU22 | HPU22 | 869 |  | 00 |  | 200 | 200 | 400 | E | LND | L2 | P | U | PU93 | LUZ2 | E | LND |  | DFA |  |
| HPU30 | PU - Remaining Equipment PO's | level of effort | 150d | 2009-12-17 A | 2010-07-26 A | P3U22L SS, P3U07D | 100% |  |  |  |  |  |  |  |  | HPU30 | HPU30 | 869 |  | 00 |  | 200 | 200 | 400 | E | LND | L2 | P | U | PU93 | LUZ2 | E | LND |  | DFA |  |
| P3U22L | PU22 Vacuum System - Lead Time/Fabrication |  | 428d | 2009-12-17 A | 2011-02-24 A | P3U22D1, P3U22D2 | 100% |  |  |  |  |  | TB26 - 2 - Manuf and Delivy |  |  | P3U22L | P3U22L | 860 | PU22 | 00 | 2DC9170 | 200 | 200 | 400 | P | LND | 0 | P | U | PU96 | LUZ2 | E | LND |  | DEL |  |
| P3U07D | PU07 Packaging Syst. - PO issued | milestone | 0d | 2009-12-17 A | 2009-12-17 A | P3U07C, P3U07F1 | 100% |  |  |  |  |  |  | 384,950 | 384,950 | P3U07D | P3U07D | 860 | PU07 | 00 | 2DC9020 | 200 | 200 | 400 | P | LND | C2 | P | U | PU33 | LUZ2 | P | LND | DC |  |  |
| HPU07 | Pack. Syst. (PU07) PO/Fabr./Transport to Site | level of effort | 450d | 2009-12-18 A | 2011-09-23 | P3U07L SS |  | 17d | 30d | 0d |  |  |  |  |  | HPU07 | HPU07 | 869 |  | 00 |  | 200 | 200 | 400 | E | LND | L2 | P | U | PU93 | LUZ2 | E | LND |  | DFA |  |
| P3U07L | PU07 Packaging Syst. - Lead Time/Fabrication |  | 403d | 2009-12-18 A | 2011-01-31 A | P3U07D | 100% |  |  |  |  |  | TB26 - 2 - Manuf and Delivy |  |  | P3U07L | P3U07L | 860 | PU07 | 00 | 2DC9020 | 200 | 200 | 400 | P | LND | C2 | P | U | PU36 | LUZ2 | E | LND | DC | DEL |  |
| P3U15D2 | PU15 Reactor Seal Oil Pack - PO issued (Equipm.) | milestone | 0d | 2009-12-18 A | 2009-12-18 A | P3U15D1 FS+85d, P3U15C FF, E3U1520 FF | 100% |  |  |  |  |  |  | 153,400 | 153,400 | P3U15D2 | P3U15D2 | 860 | PU15 | 00 | 2DC8910 | 200 | 200 | 400 | P | LND | 0 | P | U | PU93 | LUZ2 | P | LND |  |  |  |
| P3U15L | PU15 Reactor Seal Oil Pa - Lead Time/Fabrication |  | 520d | 2009-12-19 A | 2011-05-30 A | P3U15D2 | 100% |  |  |  |  |  | TB26 - 2 - Manuf and Delivy |  |  | P3U15L | P3U15L | 860 | PU15 | 00 | 2DC8910 | 200 | 200 | 400 | P | LND | 0 | P | U | PU96 | LUZ2 | E | LND |  | DEL |  |
| HPU15 | Seal Oil Pck. (PU15) PO/Fabr./Transport to Site | level of effort | 431d | 2009-12-21 A | 2011-08-30 A | P3U15L SS | 100% |  |  |  |  |  |  |  |  | HPU15 | HPU15 | 869 |  | 00 |  | 200 | 200 | 400 | E | LND | L2 | P | U | PU93 | LUZ2 | E | LND |  | DFA |  |
| HPU06 | Bagging Syst. (PU06) PO/Fabr./Transport to Site | level of effort | 383d | 2010-01-29 A | 2011-07-28 A | P3U06L SS | 100% |  |  |  |  |  |  |  |  | HPU06 | HPU06 | 869 |  | 00 |  | 200 | 200 | 400 | E | LND | L2 | P | U | PU93 | LUZ2 | E | LND |  | DFA |  |
| P3U06L | PU06 Bagging System - Lead Time/Fabrication |  | 386d | 2010-01-29 A | 2011-02-22 A | P3U06D | 100% |  |  |  |  |  | TB26 - 2 - Manuf and Delivy |  |  | P3U06L | P3U06L | 860 | PU06 | 00 | 2DC9010 | 200 | 200 | 400 | P | LND | C2 | P | U | PU36 | LUZ2 | E | LND | DC | DEL |  |
| P3U06D | PU06 Bagging System - PO issued | milestone | 0d | 2010-01-29 A | 2010-01-29 A | P3U06C FF, F2920 FF, HPU30 FF, P3U06F FF, E3U0630 FF, IMS-P-000040 FF | 100% |  |  |  |  |  |  | 217,770.8 | 217,770.8 | P3U06D | P3U06D | 860 | PU06 | 00 | 2DC9010 | 200 | 200 | 400 | P | LND | C2 | P | U | PU33 | LUZ2 | P | LND | DC |  |  |
| P3U10N1G | PU10 Gost R Certificate to russ. customs | milestone | 0d | 2010-03-09 A | 2010-03-09 A | P3U10N1 FF-90d | 100% |  |  |  |  |  | TB26 - 2 - Manuf and Delivy |  |  | P3U10N1G | P3U10N1G | 860 | PU10 | 00 | 2DC8990 | 200 | 200 | 400 | P | LND | 0 | P | U | PU18 | LUZ2 | E | LND |  |  |  |
| P3U10X1 | PU10 Convey. Syst. - Final Inspection 1st LOT |  | 5d | 2010-03-24 A | 2010-03-28 A | P3U10L SS+550d, E3U1060 FF+10d | 100% |  |  |  |  |  | TB26 - 2 - Manuf and Delivy | 2,806,701.6 | 2,806,701.6 | P3U10X1 | P3U10X1 | 860 | PU10 | 00 | 2DC8990 | 200 | 200 | 400 | P | LND | C2 | P | U | PU17 | LUZ2 | E | LND | DC |  |  |
| P3U02M | PU02 Add. Feed Syst - Goods delivered FOB or FCA main Eqpt | milestone | 0d | 2010-04-16 A | 2010-04-16 A | P3U02L FF-50d | 100% |  |  |  |  |  | TB26 - 2 - Manuf and Delivy | 846,012.3 | 846,012.3 | P3U02M | P3U02M | 860 | PU02 | 00 | 2DC9820 | 200 | 200 | 400 | P | LND | C2 | P | U | PU28 | LUZ2 | E | LND | DC |  |  |
| P3U10M1 | PU10 Convey. Syst. - Goods delivered FOB 1st LOT | milestone | 0d | 2010-04-17 A | 2010-04-17 A | P3U10X1 FF+20d | 100% |  |  |  |  |  | TB26 - 2 - Manuf and Delivy | 1,403,350.8 | 1,403,350.8 | P3U10M1 | P3U10M1 | 860 | PU10 | 00 | 2DC8990 | 200 | 200 | 400 | P | LND | C2 | P | U | PU18 | LUZ2 | E | LND | DC |  |  |
| P3U05F | PU05 Big Bag L. Station - Bid tab Client appr. |  | 11d | 2010-07-02 A | 2010-07-16 A | E3U0530 | 100% |  |  |  |  |  |  |  |  | P3U05F | P3U05F | 860 | PU05 | 00 | 2DC9640 | 200 | 200 | 400 | P | PMT | 0 | P | U | PU92 | LUZ2 | E | PMT |  |  |  |
| P3U10X4 | PU10 Convey. Syst. - Final Inspection 2nd LOT |  | 21d | 2010-07-03 A | 2010-07-23 A | E3U1060 FF+10d, P3U10L SS+650d | 100% |  |  |  |  |  | TB26 - 2 - Manuf and Delivy | 2,494,845.9 | 2,494,845.9 | P3U10X4 | P3U10X4 | 860 | PU10 | 00 | 2DC8990 | 200 | 200 | 400 | P | LND | C2 | P | U | PU17 | LUZ2 | E | LND | DC |  |  |
| P3U05D | PU05 Big Bag L. Station - PO issued | milestone | 0d | 2010-07-26 A | 2010-07-26 A | F2940 FF, HPU30 FF, P3U05C FF, P3U05F FF, E3U0530 FF | 100% |  |  |  |  |  |  | 21,835.2 | 21,835.2 | P3U05D | P3U05D | 860 | PU05 | 00 | 2DC9640 | 200 | 200 | 400 | P | LND | 0 | P | U | PU93 | LUZ2 | P | LND |  |  |  |
| HPU05 | Big Bag Station(PU05) PO/Fabr./Transport to Site | level of effort | 329d | 2010-07-27 A | 2011-11-04 | P3U05L SS |  | 45d | 406.5d | 0d |  |  |  |  |  | HPU05 | HPU05 | 869 |  | 00 |  | 200 | 200 | 400 | E | LND | L2 | P | U | PU93 | LUZ2 | E | LND |  | DFA |  |
| P3U05L | PU05 Big Bag L. Station - Lead Time/Fabrication |  | 427d | 2010-07-27 A | 2011-09-30 | P3U05D | 80% | 30d | 576.5d | 0d |  | 2011-09-30 | TB26 - 2 - Manuf and Delivy |  |  | P3U05L | P3U05L | 860 | PU05 | 00 | 2DC9640 | 200 | 200 | 400 | P | LND | 0 | P | U | PU96 | LUZ2 | E | LND |  | DEL |  |
| P3U02G | PU02 Gost R Certificate to russ. customs | milestone | 0d | 2010-08-22 A | 2010-08-22 A | P3U02N FF-90d | 100% |  |  |  |  |  | TB26 - 2 - Manuf and Delivy |  |  | P3U02G | P3U02G | 860 | PU02 | 00 | 2DC9820 | 200 | 200 | 400 | P | LND | 0 | P | U | PU28 | LUZ2 | E | LND |  |  |  |
| P3U10M4 | PU10 Convey. Syst. - Goods delivered FOB 2nd LOT | milestone | 0d | 2010-09-21 A | 2010-09-21 A | P3U10X4 FF+60d | 100% |  |  |  |  |  | TB26 - 2 - Manuf and Delivy | 1,247,422.95 | 1,247,422.95 | P3U10M4 | P3U10M4 | 860 | PU10 | 00 | 2DC8990 | 200 | 200 | 400 | P | LND | C2 | P | U | PU18 | LUZ2 | E | LND | DC |  |  |
| P3U10N1 | PU10 Convey. Syst. - Transport to Site 1st LOT depends on prov. TSF Area |  | 31d | 2010-09-22 A | 2010-10-22 A | P3U10M1, P3D1010, P3U10X1, P3D1000 (other project) FS+9d | 100% |  |  |  |  |  | TB26 - 2 - Manuf and Delivy |  |  | P3U10N1 | P3U10N1 | 860 | PU10 | 00 | 2DC8990 | 200 | 200 | 400 | P | LND | C2 | P | U | PU18 | LUZ2 | E | LND | DC |  |  |
| P3U22G | PU22 Gost R Certificate to russ. customs | milestone | 0d | 2010-10-17 A | 2010-10-17 A | P3U22N FF-90d | 100% |  |  |  |  |  | TB26 - 2 - Manuf and Delivy |  |  | P3U22G | P3U22G | 860 | PU22 | 00 | 2DC9170 | 200 | 200 | 400 | P | LND | 0 | P | U | PU98 | LUZ2 | E | LND |  |  |  |
| P3U02N | PU02 Add. Feed Syst. - Transport to Site, 1st shipment |  | 31d | 2010-10-26 A | 2010-11-25 A | P3U02M, P3U02L, P3U02X | 100% |  |  |  |  |  | TB26 - 2 - Manuf and Delivy |  |  | P3U02N | P3U02N | 860 | PU02 | 00 | 2DC9820 | 200 | 200 | 400 | P | LND | C2 | P | U | PU28 | LUZ2 | E | LND | DC |  |  |
| P3U15G | PU15 Gost R Certificate to russ. customs | milestone | 0d | 2010-11-11 A | 2010-11-11 A | P3U15N FF-90d | 100% |  |  |  |  |  | TB26 - 2 - Manuf and Delivy |  |  | P3U15G | P3U15G | 860 | PU15 | 00 | 2DC8910 | 200 | 200 | 400 | P | LND | 0 | P | U | PU98 | LUZ2 | E | LND |  |  |  |
| P3U10N4 | PU10 Convey. Syst. - Transport to Site 2nd LOT depends on prov. TSF Area |  | 30d | 2010-11-24 A | 2010-12-23 A | P3D1000 (other project), P3U10M4, P3D1010, P3U10X4 | 100% |  |  |  |  |  | TB26 - 2 - Manuf and Delivy |  |  | P3U10N4 | P3U10N4 | 860 | PU10 | 00 | 2DC8990 | 200 | 200 | 400 | P | LND | C2 | P | U | PU18 | LUZ2 | E | LND | DC |  |  |
| P3U10X3 | PU10 Convey. Syst. - Final Inspection 3rd LOT |  | 2d | 2010-11-24 A | 2010-11-25 A | E3U1060 FF+10d, P3U10L FF-5d | 100% |  |  |  |  |  | TB26 - 2 - Manuf and Delivy | 935,567.1 | 935,567.1 | P3U10X3 | P3U10X3 | 860 | PU10 | 00 | 2DC8990 | 200 | 200 | 400 | P | LND | C2 | P | U | PU17 | LUZ2 | E | LND | DC |  |  |
| P3U10M3 | PU10 Convey. Syst. - Goods delivered FOB 3rd LOT | milestone | 0d | 2010-12-10 A | 2010-12-10 A | P3U10X3 FF+10d, P3U10L FS+10d | 100% |  |  |  |  |  | TB26 - 2 - Manuf and Delivy | 467,783.55 | 467,783.55 | P3U10M3 | P3U10M3 | 860 | PU10 | 00 | 2DC8990 | 200 | 200 | 400 | P | LND | C2 | P | U | PU18 | LUZ2 | E | LND | DC |  |  |
| P3U07X | PU07 Packaging Syst. - Final Inspection |  | 2d | 2010-12-20 A | 2010-12-21 A | P3U07L FF-5d, E3U0760 | 100% |  |  |  |  |  | TB26 - 2 - Manuf and Delivy | 577,425 | 577,425 | P3U07X | P3U07X | 860 | PU07 | 00 | 2DC9020 | 200 | 200 | 400 | P | LND | C2 | P | U | PU37 | LUZ2 | E | LND | DC |  |  |
| P3U10N3 | PU10 Convey. Syst. - Transport to Site 3rd LOT |  | 32d | 2010-12-20 A | 2011-01-23 A | P3U10M3, P3U10X3 | 100% |  |  |  | start on 2011-01-10 |  | TB26 - 2 - Manuf and Delivy |  |  | P3U10N3 | P3U10N3 | 860 | PU10 | 00 | 2DC8990 | 200 | 200 | 400 | P | LND | C2 | P | U | PU18 | LUZ2 | E | LND | DC |  |  |
| P3U07G | PU07 Gost R Certificate to russ. customs | milestone | 0d | 2010-12-21 A | 2010-12-21 A | P3U07N FF-90d | 100% |  |  |  |  |  | TB26 - 2 - Manuf and Delivy |  |  | P3U07G | P3U07G | 860 | PU07 | 00 | 2DC9020 | 200 | 200 | 400 | P | LND | 0 | P | U | PU38 | LUZ2 | E | LND |  |  |  |
| P3U06G | PU06 Gost R Certificate to russ. customs | milestone | 0d | 2011-01-06 A | 2011-01-06 A | P3U06N FF-90d | 100% |  |  |  |  |  | TB26 - 2 - Manuf and Delivy |  |  | P3U06G | P3U06G | 860 | PU06 | 00 | 2DC9010 | 200 | 200 | 400 | P | LND | 0 | P | U | PU38 | LUZ2 | E | LND |  |  |  |
| P3U05G | PU05 Gost R Certificate to russ. customs | milestone | 0d | 2011-01-25 A | 2011-01-25 A | P3U05N FF-90d | 100% |  |  |  |  |  | TB26 - 2 - Manuf and Delivy |  |  | P3U05G | P3U05G | 860 | PU05 | 00 | 2DC9640 | 200 | 200 | 400 | P | LND | 0 | P | U | PU98 | LUZ2 | E | LND |  |  |  |
| P3U22X | PU22 Vacuum System - Final Inspection | milestone | 0d | 2011-01-31 A | 2011-01-31 A | E3U2250 FF, E3U2265, P3U22L FF-5d, E3U2260 FF | 100% |  |  |  |  |  | TB26 - 2 - Manuf and Delivy | 263,310 | 263,310 | P3U22X | P3U22X | 860 | PU22 | 00 | 2DC9170 | 200 | 200 | 400 | P | LND | 0 | P | U | PU97 | LUZ2 | E | LND |  |  |  |
| P3U07M | PU07 Packaging Syst. - Goods delivered FCA/FOB | milestone | 0d | 2011-01-31 A | 2011-01-31 A | P3U07L FF, P3U07D | 100% |  |  |  |  |  | TB26 - 2 - Manuf and Delivy | 288,712.5 | 288,712.5 | P3U07M | P3U07M | 860 | PU07 | 00 | 2DC9020 | 200 | 200 | 400 | P | LND | C2 | P | U | PU38 | LUZ2 | E | LND | DC |  |  |
| P3U06X | PU06 Bagging System - Final Inspection |  | 1.5d | 2011-02-15 A | 2011-02-16 A | P3U06L FF-6d, E3U0660 FF+10d | 100% |  |  |  |  |  | TB26 - 2 - Manuf and Delivy | 326,656.2 | 326,656.2 | P3U06X | P3U06X | 860 | PU06 | 00 | 2DC9010 | 200 | 200 | 400 | P | LND | C2 | P | U | PU37 | LUZ2 | E | LND | DC |  |  |
| P3U15X | PU15 Reactor Seal Oil Pack - Final Inspection | milestone | 0d | 2011-02-28 A | 2011-02-28 A | P3U15D2, E3U1560 FF, E3U1550 FF, E3U1565, P3U15L FF-22d | 100% |  |  |  |  |  | TB26 - 2 - Manuf and Delivy | 230,100 | 230,100 | P3U15X | P3U15X | 860 | PU15 | 00 | 2DC8910 | 200 | 200 | 400 | P | LND | 0 | P | U | PU97 | LUZ2 | E | LND |  |  |  |
| P3U06M | PU06 Bagging System - Goods delivered FOB | milestone | 0d | 2011-02-28 A | 2011-02-28 A | P3U06L FF+6d | 100% |  |  |  |  |  | TB26 - 2 - Manuf and Delivy | 163,328.1 | 163,328.1 | P3U06M | P3U06M | 860 | PU06 | 00 | 2DC9010 | 200 | 200 | 400 | P | LND | C2 | P | U | PU38 | LUZ2 | E | LND | DC |  |  |
| P3U22M | PU22 Vacuum System - Goods deliv. FOB/FCA | milestone | 0d | 2011-03-16 A | 2011-03-16 A | P3U22D2, P3U22X FF, P3U22L FF+20d | 100% |  |  |  |  |  | TB26 - 2 - Manuf and Delivy | 131,655 | 131,655 | P3U22M | P3U22M | 860 | PU22 | 00 | 2DC9170 | 200 | 200 | 400 | P | LND | 0 | P | U | PU98 | LUZ2 | E | LND |  |  |  |
| P3U05X | PU05 Big Bag L. Station - Final Inspection | milestone | 0d | 2011-04-28 A | 2011-04-28 A | E3U0550 FF, P3U05L FF-4d, E3U0560 FF | 100% |  |  |  |  |  | TB26 - 2 - Manuf and Delivy | 32,752.8 | 32,752.8 | P3U05X | P3U05X | 860 | PU05 | 00 | 2DC9640 | 200 | 200 | 400 | P | LND | 0 | P | U | PU97 | LUZ2 | E | LND |  |  |  |
| P3U12G | PU12 Gost R Certificate to russ. customs | milestone | 0d | 2011-06-07 A | 2011-06-07 A | P3U12N FF-90d | 100% |  |  |  |  |  | TB26 - 2 - Manuf and Delivy |  |  | P3U12G | P3U12G | 860 | PU12 | 00 | 2KB4240 | 200 | 200 | 400 | P | LND | 0 | P | U | PU98 | LUZ2 | E | LND |  |  |  |
| P3U15M | PU15 Reactor Seal Oil Pack - Goods deliv. FOB/FCA | milestone | 0d | 2011-06-09 A | 2011-06-09 A | P3U15X FF, P3U15L FF+10d | 100% |  |  |  |  |  | TB26 - 2 - Manuf and Delivy | 115,050 | 115,050 | P3U15M | P3U15M | 860 | PU15 | 00 | 2DC8910 | 200 | 200 | 400 | P | LND | 0 | P | U | PU98 | LUZ2 | E | LND |  |  | x |
| P3U22N | PU22 Vacuum System - Transport to Site |  | 43d | 2011-06-15 A | 2011-07-27 A | P3U22M, P3B100 FF | 100% |  |  |  | start on 2011-06-15 |  | TB26 - 2 - Manuf and Delivy |  |  | P3U22N | P3U22N | 860 | PU22 | 00 | 2DC9170 | 200 | 200 | 400 | P | LND | 0 | P | U | PU98 | LUZ2 | E | LND |  |  |  |
| P3U06N | PU06 Bagging System - Transport to Site |  | 31d | 2011-06-28 A | 2011-07-28 A | P3U06X, P3U06L, P3U06M FS+15d | 100% |  |  |  |  |  | TB26 - 2 - Manuf and Delivy |  |  | P3U06N | P3U06N | 860 | PU06 | 00 | 2DC9010 | 200 | 200 | 400 | P | LND | C2 | P | U | PU38 | LUZ2 | E | LND | DC |  |  |
| P3U12X | PU12 Propyl.Recov.Unit - Final Inspection | milestone | 0d | 2011-07-05 A | 2011-07-05 A | P3U12L FF-8d, E3U1265, E3U1250 FF, P3U12D, E3U1260 FF | 100% |  |  |  |  |  | TB26 - 2 - Manuf and Delivy | 2,037,992.1 | 2,037,992.1 | P3U12X | P3U12X | 860 | PU12 | 00 | 2KB4240 | 200 | 200 | 400 | P | LND | 0 | P | U | PU97 | LUZ2 | E | LND |  |  |  |
| P3U15N | PU15 Reactor Seal Oil Pack - Transport to Site |  | 27d | 2011-08-04 A | 2011-08-30 A | P3U15M FS+55d | 100% |  |  |  |  |  | TB26 - 2 - Manuf and Delivy |  |  | P3U15N | P3U15N | 860 | PU15 | 00 | 2DC8910 | 200 | 200 | 400 | P | LND | 0 | P | U | PU98 | LUZ2 | E | LND |  |  |  |
| P3U07N | PU07 Packaging Syst. - Transport to Site (class. decision still open !) |  | 30d | 2011-08-26 A | 2011-09-24 | P3U07L, P3U07X, P3U07M FS+20d |  | 24d | 45d | 0d | start on 2011-08-26 |  | TB26 - 2 - Manuf and Delivy |  |  | P3U07N | P3U07N | 860 | PU07 | 00 | 2DC9020 | 200 | 200 | 400 | P | LND | C2 | P | U | PU38 | LUZ2 | E | LND | DC |  |  |
| P3U05M | PU05 Big Bag L. Station - Goods deliv. FOB | milestone | 0d | 2011-10-05 | 2011-10-05 | P3U05L FF+5d |  |  | 576.5d | 0d |  |  | TB26 - 2 - Manuf and Delivy | 16,376.4 |  | P3U05M | P3U05M | 860 | PU05 | 00 | 2DC9640 | 200 | 200 | 400 | P | LND | 0 | P | U | PU98 | LUZ2 | E | LND |  |  |  |
| P3U05N | PU05 Big Bag L. Station - Transport to Site |  | 30d | 2011-10-06 | 2011-11-04 | P3U05M |  |  | 576.5d | 0d |  |  | TB26 - 2 - Manuf and Delivy |  |  | P3U05N | P3U05N | 860 | PU05 | 00 | 2DC9640 | 200 | 200 | 400 | P | LND | 0 | P | U | PU98 | LUZ2 | E | LND |  |  |  |

Notes:
- P3U02X: Expenses: 900A 1692025
- P3U22D2: Expenses: 900A 175540
- HPU22: UDF_Actictity Name (Russia): Система улавливания сдувок (PU22), заказ на поставку/изготовление/транспортировка на площадку
- HPU30: UDF_Actictity Name (Russia): Комплектные установки - Оставшиеся заказы на поставку оборудования
- P3U07D: Expenses: 900A 384950
- HPU07: UDF_Actictity Name (Russia): Система упаковки (PU07), заказ на поставку/изготовление/транспортировка на площадку
- P3U15D2: Expenses: 900A 153400
- HPU15: UDF_Actictity Name (Russia): Блок уплотняющего масла (PU15), заказ на поставку/изготовление/транспортировка на площадку
- HPU06: UDF_Actictity Name (Russia): Система расфасовки (PU06), заказ на поставку/изготовление/транспортировка на площадку
- P3U06D: Expenses: 900A 217771
- P3U10X1: Expenses: 900A 2806702
- P3U02M: Expenses: 900A 846012
- P3U10M1: Expenses: 900A 1403351
- P3U10X4: Expenses: 900A 2494846
- P3U05D: Expenses: 900A 21835.2
- HPU05: UDF_Actictity Name (Russia): Станция загрузки больших мешков (PU05), заказ на поставку/изготовление/транспортировка на площадку
- P3U10M4: Expenses: 900A 1247423
- P3U10N1: P3 Activity Log Info: per Rail (Bulk - piping, / bends, flanges) + rotary feeder, diverter valves, etc.
- P3U02N: P3 Activity Log Info: Rail
- P3U10N4: P3 Activity Log Info: per Rail(Bulk, HE,Filter, / Vessels, Hopp.) (Scales, Bagstations,etc.)
- P3U10X3: Expenses: 900A 935567
- P3U10M3: Expenses: 900A 467784
- P3U07X: Expenses: 900A 577425
- P3U10N3: P3 Activity Log Info: per Rail(Compressors, / Blowers, Control System)
- P3U22X: Expenses: 900A 263310
- P3U07M: Expenses: 900A 288712
- P3U06X: Expenses: 900A 326656
- P3U15X: Expenses: 900A 230100
- P3U06M: Expenses: 900A 163328
- P3U22M: Expenses: 900A 131655
- P3U05X: Expenses: 900A 32752.8
- P3U15M: Expenses: 900A 115050
- P3U06N: P3 Activity Log Info: Rail
- P3U12X: Expenses: 900A 2037992
- P3U07N: P3 Activity Log Info: Rail
- P3U05M: Expenses: 900A 16376.4

| ID | WBS | Activity | Type | Duration | Start | Finish | Predecessors | Complete | Calendar | Cost | Actual cost | UDF_SAVE ACTID | UDF_SAVE ACT ID | Department | Type of Work | Constr. Area | Pro Unit/DocCode | Inquiry/Order No | PMT-Area | PMT-Schedule Org | PMT-Discipline | PMT-Phase | PMT-Stage | PMT-Doc. Type | PMT-Respons. | Zeigen/n. Zeigen | WBS Phase | WBS Discipline | WBS Type of Work | WBS Objects | IMS | UPT |
| --- | --- | --- | --- | --- | --- | --- | --- | --- | --- | --- | --- | --- | --- | --- | --- | --- | --- | --- | --- | --- | --- | --- | --- | --- | --- | --- | --- | --- | --- | --- | --- | --- |
|  | B | **B Mechanical - Stationary Equipment** |  |  | 2007-12-20 | 2013-06-11 |  |  |  |  |  |  |  |  |  |  |  |  |  |  |  |  |  |  |  |  |  |  |  |  |  |  |
| P3A04AA |  | A04A R Overhead Cond. - Prepare/Issue RFQ |  | 99d | 2007-12-20 A | 2008-05-19 A | F1540 SS+100d | 100% |  |  |  | P3A04AA | P3A04AA | 860 | A04A | 00 | DC | 2DC9110 | 200 | 200 | 400 | P | 3A | DEV | LND | C2 | P | B | PB11 | LUZ2 | E | LND |
| P3A05A |  | A05 Offgas Cyclone&R - Prepare/Issue RFQ |  | 23d | 2007-12-20 A | 2008-01-28 A | F1540 SS, F1660 SS | 100% |  |  |  | P3A05A | P3A05A | 860 | A05 | 00 | DC | 2DC8590 | 200 | 200 | 400 | P | 3A | DEV | LND | C2 | P | B | PB11 | LUZ2 | S | LND |
| P3A07A |  | A07 R Fines Eductor - Prepare/Issue RFQ |  | 29d | 2007-12-20 A | 2008-02-05 A | F1540 SS, F1660 SS | 100% |  |  |  | P3A07A | P3A07A | 860 | A07 | 00 | DC | 2DC8640 | 200 | 200 | 400 | P | 3A | DEV | LND | C2 | P | B | PB91 | LUZ2 | E | LND |
| P3A08A |  | A08 Vent/Bag Filter - Prepare/Issue RFQ |  | 20d | 2007-12-20 A | 2008-01-23 A | F1660 SS, F1540 SS | 100% |  |  |  | P3A08A | P3A08A | 860 | A08 | 00 | DC | 2DC8560 | 200 | 200 | 400 | P | 3A | DEV | LND | C2 | P | B | PB81 | LUZ2 | S | LND |
| P3ALL2A |  | ALL2 Purge Columns - Prepare Spec./Issue RFQ |  | 18d | 2007-12-20 A | 2008-01-21 A | F1540 SS, F1660 SS | 100% |  |  |  | P3ALL2A | P3ALL2A | 860 | ALL2 | 00 | DC | 2DC8500 | 200 | 200 | 400 | P | 3A | DEV | LND | C2 | P | B | PB41 | LUZ2 | E | LND |
| P3A04A |  | A04 R Overhead Separ. - Prepare Spec./Issue RFQ |  | 10d | 2008-01-04 A | 2008-01-17 A | F1540 SS | 100% |  |  |  | P3A04A | P3A04A | 860 | A04 | 00 | DC | 2DC8500 | 200 | 200 | 400 | P |  | DEV | LND | C2 | P | B | PB11 | LUZ2 | E | LND |
| P3A16A |  | A16 Offgas C Filters - Prepare/Issue RFQ |  | 14d | 2008-01-14 A | 2008-01-31 A | F1660 SS, F1540 SS | 100% |  |  |  | P3A16A | P3A16A | 860 | A16 | 00 | DC | 2DC8560 | 200 | 200 | 400 | P | 3A | DEV | LND | C2 | P | B | PB81 | LUZ2 | E | LND |
| F8410 |  | A04 R Overhead Separ. - Vendor Bid Preparation |  | 33d | 2008-01-18 A | 2008-03-04 A | P3A04B | 100% |  |  |  | F8410 | F8410 | 860 | A04 | 00 | DC | 2DC8500 | 200 | 200 | 400 | P |  |  | LND | C2 | P | B | PB31 | LUZ2 | E | PMT |
| F8520 |  | A04 R Overhead Separ. - Issue RFQ to PMT | milestone | 0d | 2008-01-18 A | 2008-01-18 A | P3A04B FF | 100% |  |  |  | F8520 | F8520 | 860 | A04 | 00 |  | 2DC8500 | 200 | 200 | 400 | P |  |  | LND | C2 | P | B | PB11 | LUZ2 | E | PMT |
| F8530 |  | A04 R Overhead Separ. - PMT approve RFQ |  | 15d | 2008-01-18 A | 2008-02-07 A | F8520 | 100% |  |  |  | F8530 | F8530 | 860 | A04 | 00 |  | 2DC8500 | 200 | 200 | 400 | P |  |  | PMT | C2 | P | B | PB11 | LUZ2 | E | PMT |
| P3A04B |  | A04 R Overhead Separ. - RFQ issued to bidders | milestone | 0d | 2008-01-18 A | 2008-01-18 A | P3A04A FF | 100% |  | 32,184.6 | 32,184.6 | P3A04B | P3A04B | 860 | A04 | 00 | DC | 2DC8500 | 200 | 200 | 400 | P |  |  | LND | C2 | P | B | PB11 | LUZ2 | E | LND |
| F7800 |  | ALL2 Purge Columns - Vendor Bid Preparation |  | 26d | 2008-01-22 A | 2008-02-26 A | P3ALL2B | 100% |  |  |  | F7800 | F7800 | 860 | ALL2 | 00 | DC | 2DC8500 | 200 | 200 | 400 | P | 3A |  | LND | C2 | P | B | PB41 | LUZ2 | 1 | LND |
| F7920 |  | ALL2 Purge Columns - Issue RFQ to PMT | milestone | 0d | 2008-01-22 A | 2008-01-22 A | P3ALL2B FF | 100% |  |  |  | F7920 | F7920 | 860 | ALL2 | 00 |  | 2DC8500 | 200 | 200 | 400 | P | 3A |  | LND | C2 | P | B | PB41 | LUZ2 | 1 | LND |
| F7930 |  | ALL2 Purge Columns - PMT approve RFQ |  | 13d | 2008-01-22 A | 2008-02-07 A | F7920 | 100% |  |  |  | F7930 | F7930 | 860 | ALL2 | 00 |  | 2DC8500 | 200 | 200 | 400 | P | 3A |  | PMT | C2 | P | B | PB41 | LUZ2 | 1 | LND |
| P3ALL2B |  | ALL2 Purge Columns - RFQ issued to bidders | milestone | 0d | 2008-01-22 A | 2008-01-22 A | P3ALL2A FF | 100% |  | 66,086 | 66,086 | P3ALL2B | P3ALL2B | 860 | ALL2 | 00 | DC | 2DC8500 | 200 | 200 | 400 | P | 3A |  | LND | C2 | P | B | PB41 | LUZ2 | E | LND |
| F5560 |  | A08 Vent/Bag Filter - Vendor Bid Preparation |  | 33d | 2008-01-24 A | 2008-03-10 A | P3A08B | 100% |  |  |  | F5560 | F5560 | 860 | A08 | 00 | DC | 2DC8560 | 200 | 200 | 400 | P | 3A |  | LND | C2 | P | B | PB81 | LUZ2 | 1 | LND |
| F5670 |  | A08 Vent/Bag Filter - Issue RFQ to PMT | milestone | 0d | 2008-01-24 A | 2008-01-24 A | P3A08B FF | 100% |  |  |  | F5670 | F5670 | 860 | A08 | 00 |  | 2DC8560 | 200 | 200 | 400 | P | 3A |  | LND | C2 | P | B | PB81 | LUZ2 | 1 | LND |
| F5680 |  | A08 Vent/Bag Filter - PMT approve RFQ |  | 11d | 2008-01-24 A | 2008-02-07 A | F5670 | 100% |  |  |  | F5680 | F5680 | 860 | A08 | 00 |  | 2DC8560 | 200 | 200 | 400 | P | 3A |  | PMT | C2 | P | B | PB81 | LUZ2 | 1 | LND |
| P3A08B |  | A08 Vent/Bag Filter - RFQ issued to bidders | milestone | 0d | 2008-01-24 A | 2008-01-24 A | P3A08A FF | 100% |  | 60,700 | 60,700 | P3A08B | P3A08B | 860 | A08 | 00 | DC | 2DC8560 | 200 | 200 | 400 | P | 3A |  | LND | C2 | P | B | PB81 | LUZ2 | S | LND |
| F6960 |  | A05 Offgas Cyclone&R - Vendor Bid Preparation |  | 22d | 2008-01-29 A | 2008-02-27 A | P3A05B | 100% |  |  |  | F6960 | F6960 | 860 | A05 | 00 | DC | 2DC8590 | 200 | 200 | 400 | P | 3A |  | LND | C2 | P | B | PB11 | LUZ2 | 1 | LND |
| F7070 |  | A05 Offgas Cyclone&R - Issue RFQ to PMT | milestone | 0d | 2008-01-29 A | 2008-01-29 A | P3A05B FF | 100% |  |  |  | F7070 | F7070 | 860 | A05 | 00 |  | 2DC8590 | 200 | 200 | 400 | P | 3A |  | LND | C2 | P | B | PB11 | LUZ2 | 1 | LND |
| F7080 |  | A05 Offgas Cyclone&R - PMT approve RFQ |  | 8d | 2008-01-29 A | 2008-02-07 A | F7070 | 100% |  |  |  | F7080 | F7080 | 860 | A05 | 00 |  | 2DC8590 | 200 | 200 | 400 | P | 3A |  | PMT | C2 | P | B | PB11 | LUZ2 | 1 | LND |
| P3A05B |  | A05 Offgas Cyclone&R - RFQ issued to bidders | milestone | 0d | 2008-01-29 A | 2008-01-29 A | P3A05A FF | 100% |  | 17,912.2 | 17,912.2 | P3A05B | P3A05B | 860 | A05 | 00 | DC | 2DC8590 | 200 | 200 | 400 | P | 3A |  | LND | C2 | P | B | PB11 | LUZ2 | S | LND |
| F5870 |  | A16 Offgas C Filters - Issue RFQ to PMT | milestone | 0d | 2008-02-01 A | 2008-02-01 A | P3A16B FF | 100% |  |  |  | F5870 | F5870 | 860 | A16 | 00 |  | 2DC8560 | 200 | 200 | 400 | P | 3A |  | LND | C2 | P | B | PB81 | LUZ2 | 1 | LND |
| F5880 |  | A16 Offgas C Filters - PMT approve RFQ |  | 5d | 2008-02-01 A | 2008-02-07 A | F5870 | 100% |  |  |  | F5880 | F5880 | 860 | A16 | 00 |  | 2DC8560 | 200 | 200 | 400 | P | 3A |  | PMT | C2 | P | B | PB81 | LUZ2 | 1 | LND |
| P3A16B |  | A16 Offgas C Filters - RFQ issued to bidders | milestone | 0d | 2008-02-01 A | 2008-02-01 A | P3A16A FF | 100% |  | 19,100 | 19,100 | P3A16B | P3A16B | 860 | A16 | 00 | DC | 2DC8560 | 200 | 200 | 400 | P | 3A |  | LND | C2 | P | B | PB81 | LUZ2 | E | LND |
| F5760 |  | A16 Offgas C Filters - Vendor Bid Preparation |  | 38d | 2008-02-04 A | 2008-03-28 A | P3A16B | 100% |  |  |  | F5760 | F5760 | 860 | A16 | 00 | DC | 2DC8560 | 200 | 200 | 400 | P | 3A |  | LND | C2 | P | B | PB81 | LUZ2 | 1 | LND |
| F5170 |  | A07 R Fines Eductor - Issue RFQ to PMT | milestone | 0d | 2008-02-06 A | 2008-02-06 A | P3A07B FF | 100% |  |  |  | F5170 | F5170 | 860 | A07 | 00 |  | 2DC8640 | 200 | 200 | 400 | P | 3A |  | LND | C2 | P | B | PB91 | LUZ2 | 1 | LND |
| F5180 |  | A07 R Fines Eductor - PMT approve RFQ |  | 5d | 2008-02-06 A | 2008-02-12 A | F5170 | 100% |  |  |  | F5180 | F5180 | 860 | A07 | 00 |  | 2DC8640 | 200 | 200 | 400 | P | 3A |  | PMT | C2 | P | B | PB91 | LUZ2 | 1 | LND |
| P3A07B |  | A07 R Fines Eductor - RFQ issued to bidders | milestone | 0d | 2008-02-06 A | 2008-02-06 A | P3A07A FF | 100% |  | 7,130 | 7,130 | P3A07B | P3A07B | 860 | A07 | 00 | DC | 2DC8640 | 200 | 200 | 400 | P | 3A |  | LND | C2 | P | B | PB91 | LUZ2 | E | LND |
| F5060 |  | A07 R Fines Eductor - Vendor Bid Preparation |  | 32d | 2008-02-11 A | 2008-03-27 A | P3A07B | 100% |  |  |  | F5060 | F5060 | 860 | A07 | 00 | DC | 2DC8640 | 200 | 200 | 400 | P | 3A |  | LND | C2 | P | B | PB91 | LUZ2 | 1 | LND |
| HPBALL1 |  | Reactor Pck. (ALL1) PO/Fabr./Transport to Site | level of effort | 637d | 2008-02-13 A | 2010-08-27 A | P3ALL1L SS | 100% |  |  |  | HPBALL1 | HPBALL1 | 869 |  | 00 |  |  | 200 | 200 | 400 | E |  | DFA | LND | L2 | P | B | PB93 | LUZ2 | E | LND |
| F7940 |  | ALL2 Purge Columns - Vendor Bid for INEOS Review | milestone | 0d | 2008-02-26 A | 2008-02-26 A | F7930, F7800 | 100% |  |  |  | F7940 | F7940 | 860 | ALL2 | 00 |  | 2DC8500 | 200 | 200 | 400 | P | 3A |  | LND | C2 | P | B | PB42 | LUZ2 | 1 | LND |
| F7090 |  | A05 Offgas Cyclone&R - Vendor Bid for INEOS Rev | milestone | 0d | 2008-02-28 A | 2008-02-28 A | F7080, F6960 | 100% |  |  |  | F7090 | F7090 | 860 | A05 | 00 |  | 2DC8590 | 200 | 200 | 400 | P | 3A |  | LND | C2 | P | B | PB12 | LUZ2 | 1 | LND |
| F8540 |  | A04 R Overhead Sep.- Vendor Bid for INEOS Review | milestone | 0d | 2008-03-04 A | 2008-03-04 A | F8410 | 100% |  |  |  | F8540 | F8540 | 860 | A04 | 00 |  | 2DC8500 | 200 | 200 | 400 | P |  |  | LND | C2 | P | B | PB12 | LUZ2 | E | PMT |
| P3A01A |  | A01 Drums/Small Vessels - Prepare/Issue RFQ |  | 3d | 2008-03-06 A | 2008-03-10 A | E3A0110 | 100% |  |  |  | P3A01A | P3A01A | 860 | A01 | 00 |  | 2DD8530 | 200 | 200 | 400 | P |  | DEV | LND | 0 | P | B | PB11 | LUZ2 | E | LND |
| P3A01B |  | A01 Drums/Small Vessels - RFQ issued | milestone | 0d | 2008-03-11 A | 2008-03-11 A | P3A01A FF | 100% |  | 20,508 | 20,508 | P3A01B | P3A01B | 860 | A01 | 00 |  | 2DD8530 | 200 | 200 | 400 | P |  | DEV | LND | 0 | P | B | PB11 | LUZ2 | E | LND |
| F5690 |  | A08 Vent/Bag Filter- Vendor Bid for INEOS Review | milestone | 0d | 2008-03-14 A | 2008-03-14 A | F5560, F5680 | 100% |  |  |  | F5690 | F5690 | 860 | A08 | 00 |  | 2DC8560 | 200 | 200 | 400 | P | 3A |  | LND | C2 | P | B | PB82 | LUZ2 | 1 | LND |
| P3A04C |  | A04 R Overhead Separ. - Eval./Negotiation |  | 64d | 2008-03-17 A | 2008-06-18 A | F8460 FS+2d | 100% |  |  |  | P3A04C | P3A04C | 860 | A04 | 00 | DC | 2DC8500 | 200 | 200 | 400 | P |  |  | LND | C2 | P | B | PB12 | LUZ2 | E | LND |
| P3ALL2C |  | ALL2 Purge Columns - Eval./Negotiation |  | 64d | 2008-03-17 A | 2008-06-18 A | F7850 | 100% |  |  |  | P3ALL2C | P3ALL2C | 860 | ALL2 | 00 | DC | 2DC8500 | 200 | 200 | 400 | P | 3A |  | LND | C2 | P | B | PB42 | LUZ2 | E | LND |
| P3A05C |  | A05 Offgas Cyclone&R - Eval./Negotiation |  | 41d | 2008-03-26 A | 2008-05-23 A | F7010 FS+3d | 100% |  |  |  | P3A05C | P3A05C | 860 | A05 | 00 | DC | 2DC8590 | 200 | 200 | 400 | P | 3A |  | LND | C2 | P | B | PB12 | LUZ2 | S | LND |
| F5190 |  | A07 R Fines Eductor- Vendor Bid for INEOS Review | milestone | 0d | 2008-03-27 A | 2008-03-27 A | F5180, F5060 | 100% |  |  |  | F5190 | F5190 | 860 | A07 | 00 |  | 2DC8640 | 200 | 200 | 400 | P | 3A |  | LND | C2 | P | B | PB92 | LUZ2 | 1 | LND |
| F5890 |  | A16 Offgas C Filter- Vendor Bid for INEOS Review | milestone | 0d | 2008-03-28 A | 2008-03-28 A | F5760, F5880 | 100% |  |  |  | F5890 | F5890 | 860 | A16 | 00 |  | 2DC8560 | 200 | 200 | 400 | P | 3A |  | LND | C2 | P | B | PB82 | LUZ2 | 1 | LND |
| P3A06AA |  | A06A Electrical Heater - Prepare/Issue RFQ |  | 6d | 2008-04-21 A | 2008-04-28 A | E3A06A10 | 100% |  |  |  | P3A06AA | P3A06AA | 860 | A06A | 00 |  | 2DC9080 | 200 | 200 | 400 | P |  | DEV | LND | 0 | P | B | PB21 | LUZ2 | E | LND |
| P3A07C |  | A07 R Fines Eductor - Eval./Negotiation |  | 52d | 2008-04-21 A | 2008-07-03 A | F5110 FS+5d | 100% |  |  |  | P3A07C | P3A07C | 860 | A07 | 00 | DC | 2DC8640 | 200 | 200 | 400 | P | 3A |  | LND | C2 | P | B | PB92 | LUZ2 | E | LND |
| P3ALL4A |  | ALL4 Silo's - Prepare Spec./Issue RFQ |  | 14d | 2008-04-21 A | 2008-05-09 A | F5467 | 100% |  |  |  | P3ALL4A | P3ALL4A | 860 | ALL4 | 00 | DC | 2DC9000 | 200 | 200 | 400 | P |  | DEV | LND | C2 | P | B | PB61 | LUZ2 | S | LND |
| P3A16C |  | A16 Offgas C Filters - Eval./Negotiation |  | 42d | 2008-04-22 A | 2008-06-20 A | F5810 FS+15d | 100% |  |  |  | P3A16C | P3A16C | 860 | A16 | 00 | DC | 2DC8560 | 200 | 200 | 400 | P | 3A |  | LND | C2 | P | B | PB82 | LUZ2 | E | LND |
| P3A08C |  | A08 Vent/Bag Filter - Eval./Negotiation |  | 41d | 2008-04-23 A | 2008-06-20 A | F5610 FS+25d | 100% |  |  |  | P3A08C | P3A08C | 860 | A08 | 00 | DC | 2DC8560 | 200 | 200 | 400 | P | 3A |  | LND | C2 | P | B | PB82 | LUZ2 | S | LND |
| P3A06AB |  | A06A Electrical Heater - RFQ issued | milestone | 0d | 2008-04-29 A | 2008-04-29 A | P3A06AA FF | 100% |  | 3,761 | 3,761 | P3A06AB | P3A06AB | 860 | A06A | 00 |  | 2DC9080 | 200 | 200 | 400 | P |  | DEV | LND | 0 | P | B | PB21 | LUZ2 | E | LND |
| F7140 |  | A05 Offgas Cyclone&R - Bid tab Client appr. |  | 5d | 2008-05-02 A | 2008-05-08 A | E3A0530, P3A05C FF | 100% |  |  |  | F7140 | F7140 | 860 | A05 | 00 |  | 2DC8590 | 200 | 200 | 400 | P | 3A |  | PMT | C2 | P | B | PB12 | LUZ2 | 1 | LND |
| F10010 |  | ALL4 Silo's - Issue RFQ to PMT | milestone | 0d | 2008-05-10 A | 2008-05-10 A | P3ALL4A FF | 100% |  |  |  | F10010 | F10010 | 860 | ALL4 | 00 | DC | 2DC9000 | 200 | 200 | 400 | P |  |  | LND | C2 | P | B | PB61 | LUZ2 | 1 | LND |
| F10020 |  | ALL4 Silo's - PMT approve RFQ |  | 7d | 2008-05-13 A | 2008-05-21 A | F10010 | 100% |  |  |  | F10020 | F10020 | 860 | ALL4 | 00 | DC | 2DC9000 | 200 | 200 | 400 | P |  |  | PMT | C2 | P | B | PB61 | LUZ2 | 1 | LND |
| P3A13A |  | A13 Scales - Prepare/Issue RFQ |  | 4d | 2008-05-19 A | 2008-05-22 A | E3A1310 | 100% |  |  |  | P3A13A | P3A13A | 860 | A13 | 00 |  | 2DC9060 | 200 | 200 | 400 | P |  | DEV | LND | 0 | P | B | PB91 | LUZ2 | S | LND |
| F5370 |  | A04A R Overhead Cond. - Issue RFQ to PMT | milestone | 0d | 2008-05-20 A | 2008-05-20 A | P3A04AA FF | 100% |  |  |  | F5370 | F5370 | 860 | A04A | 00 |  | 2DC9110 | 200 | 200 | 400 | P | 3A |  | LND | C2 | P | B | PB11 | LUZ2 | 1 | LND |
| F5380 |  | A04A R Overhead Cond. - PMT approve RFQ |  | 7d | 2008-05-20 A | 2008-05-28 A | F5370 | 100% |  |  |  | F5380 | F5380 | 860 | A04A | 00 |  | 2DC9110 | 200 | 200 | 400 | P | 3A |  | PMT | C2 | P | B | PB11 | LUZ2 | 1 | LND |
| F10040 |  | ALL4 Silo's - Vendor Bid Preparation |  | 19d | 2008-05-22 A | 2008-06-17 A | P3ALL4B | 100% |  |  |  | F10040 | F10040 | 860 | ALL4 | 00 | DC | 2DC9000 | 200 | 200 | 400 | P |  |  | LND | C2 | P | B | PB61 | LUZ2 | 1 | LND |
| F7900 |  | ALL2 Purge Columns - Bid tab Client appr. |  | 16d | 2008-05-22 A | 2008-06-12 A | P3ALL2C FF, E3ALL230 | 100% |  |  |  | F7900 | F7900 | 860 | ALL2 | 00 |  | 2DC8500 | 200 | 200 | 400 | P | 3A |  | PMT | C2 | P | B | PB42 | LUZ2 | 1 | LND |
| P3ALL4B |  | ALL4 Silo's - RFQ issued to Bidders | milestone | 0d | 2008-05-22 A | 2008-05-22 A | P3ALL4A FF, F10020 FF | 100% |  | 193,645 | 193,645 | P3ALL4B | P3ALL4B | 860 | ALL4 | 00 | DC | 2DC9000 | 200 | 200 | 400 | P |  |  | LND | C2 | P | B | PB61 | LUZ2 | S | LND |
| P3A13B |  | A13 Scales - RFQ issued | milestone | 0d | 2008-05-23 A | 2008-05-23 A | P3A13A FF | 100% |  | 11,860.8 | 11,860.8 | P3A13B | P3A13B | 860 | A13 | 00 |  | 2DC9060 | 200 | 200 | 400 | P |  | DEV | LND | 0 | P | B | PB91 | LUZ2 | S | LND |
| P3A05D1 |  | A05 Offgas Cyclone&R - PO issued (Engineering) | milestone | 0d | 2008-05-24 A | 2008-05-24 A | E3A0520, F7140 | 100% |  |  |  | P3A05D1 | P3A05D1 | 860 | A05 | 00 | DC | 2DC8590 | 200 | 200 | 400 | P | 3A |  | LND | C2 | P | B | PB13 | LUZ2 | S | LND |
| P3A05L |  | A05 Offgas Cyclone&R - Lead Time/Fabrication |  | 760d | 2008-05-24 A | 2010-06-30 A | P3A05D1 | 100% | TB26 - 2 - Manuf and Delivy |  |  | P3A05L | P3A05L | 860 | A05 | 00 | DC | 2DC8590 | 200 | 200 | 400 | P |  | DEL | LND | C2 | P | B | PB16 | LUZ2 | E | LND |
| P3A06A |  | A06 Start-Up Heater/Condenser - Prepare/Issue RFQ |  | 4d | 2008-05-26 A | 2008-05-29 A | E3A0610 | 100% |  |  |  | P3A06A | P3A06A | 860 | A06 | 00 |  | 2DD8530 | 200 | 200 | 400 | P |  | DEV | LND | 0 | P | B | PB21 | LUZ2 | E | LND |
| P3A04AB |  | A04A R Overhead Cond. - RFQ issued to bidders | milestone | 0d | 2008-05-29 A | 2008-05-29 A | P3A04AA FF, F5380 FF | 100% |  | 98,850 | 98,850 | P3A04AB | P3A04AB | 860 | A04A | 00 | DC | 2DC9110 | 200 | 200 | 400 | P | 3A |  | LND | C2 | P | B | PB11 | LUZ2 | E | LND |
| P3A06B |  | A06 Start-Up Heater/Condenser - RFQ issued | milestone | 0d | 2008-05-30 A | 2008-05-30 A | P3A06A FF | 100% |  | 9,320 | 9,320 | P3A06B | P3A06B | 860 | A06 | 00 |  | 2DD8530 | 200 | 200 | 400 | P |  | DEV | LND | 0 | P | B | PB21 | LUZ2 | E | LND |
| F5740 |  | A08 Vent/Bag Filter - Bid tab Client appr. |  | 6d | 2008-06-02 A | 2008-06-09 A | E3A0830 | 100% |  |  |  | F5740 | F5740 | 860 | A08 | 00 |  | 2DC8560 | 200 | 200 | 400 | P | 3A |  | PMT | C2 | P | B | PB82 | LUZ2 | 1 | LND |
| F5940 |  | A16 Offgas C Filters - Bid tab Client appr. |  | 5d | 2008-06-02 A | 2008-06-06 A | P3A16C FF, E3A1630 | 100% |  |  |  | F5940 | F5940 | 860 | A16 | 00 |  | 2DC8560 | 200 | 200 | 400 | P | 3A |  | PMT | C2 | P | B | PB82 | LUZ2 | 1 | LND |
| F8590 |  | A04 R Overhead Separ. - Bid tab Client appr. |  | 7d | 2008-06-04 A | 2008-06-12 A | E3A0430 | 100% |  |  |  | F8590 | F8590 | 860 | A04 | 00 |  | 2DC8500 | 200 | 200 | 400 | P |  |  | PMT | C2 | P | B | PB12 | LUZ2 | E | PMT |
| F5260 |  | A04A R Overhead Cond. - Vendor Bid Preparation |  | 32d | 2008-06-09 A | 2008-07-22 A | P3A04AB | 100% |  |  |  | F5260 | F5260 | 860 | A04A | 00 | DC | 2DC9110 | 200 | 200 | 400 | P | 3A |  | LND | C2 | P | B | PB11 | LUZ2 | 1 | LND |
| HPBALL2 |  | Purge Columns (ALL2) PO/Fabr./Transport to Site | level of effort | 547d | 2008-06-19 A | 2010-08-24 A | P3ALL2L SS | 100% |  |  |  | HPBALL2 | HPBALL2 | 869 |  | 00 |  |  | 200 | 200 | 400 | E |  | DFA | LND | L2 | P | B | PB93 | LUZ2 | E | LND |

Notes:
- P3A04B: Expenses: 900A 32184.6
- P3ALL2B: Expenses: 900A 66086
- P3A08B: Expenses: 900A 60700
- P3A05B: Expenses: 900A 17912.2
- P3A16B: Expenses: 900A 19100
- P3A07B: Expenses: 900A 7130
- HPBALL1: UDF_Actictity Name (Russia): Комплектная установка реактора (ALL1), заказ на поставку/изготовление/транспортировка на площадку
- P3A01B: Expenses: 900A 20508
- P3A06AB: Expenses: 900A 3761
- P3ALL4B: Expenses: 900A 193645
- P3A13B: Expenses: 900A 11860.8
- P3A04AB: Expenses: 900A 98850
- P3A06B: Expenses: 900A 9320
- HPBALL2: UDF_Actictity Name (Russia): Продувочные колонны (ALL2), заказ на поставку/изготовление/транспортировка на площадку

| ID | Activity | Type | Duration | Start | Finish | Predecessors | Complete | Calendar | Cost | Actual cost | UDF_SAVE ACTID | UDF_SAVE ACT ID | Department | Type of Work | Constr. Area | Pro Unit/DocCode | Inquiry/Order No | PMT-Area | PMT-Schedule Org | PMT-Discipline | PMT-Phase | PMT-Respons. | Zeigen/n. Zeigen | WBS Phase | WBS Discipline | WBS Type of Work | WBS Objects | IMS | UPT | PMT-Doc. Type | PMT-Stage |
| --- | --- | --- | --- | --- | --- | --- | --- | --- | --- | --- | --- | --- | --- | --- | --- | --- | --- | --- | --- | --- | --- | --- | --- | --- | --- | --- | --- | --- | --- | --- | --- |
| P3A04D | A04 R Overhead Separ. - PO issued | milestone | 0d | 2008-06-19 A | 2008-06-19 A | P3A04C FF, F8590 FF | 100% |  | 128,738.4 | 128,738.4 | P3A04D | P3A04D | 860 | A04 | 00 | DC | 2DC8500 | 200 | 200 | 400 | P | LND | C2 | P | B | PB13 | LUZ2 | E | LND |  |  |
| P3A04L | A04 R Overhead Separ. - Lead Time/Fabrication |  | 306d | 2008-06-19 A | 2009-04-23 A | P3A04D | 100% | TB26 - 2 - Manuf and Delivy |  |  | P3A04L | P3A04L | 860 | A04 | 00 | DC | 2DC8500 | 200 | 200 | 400 | P | LND | C2 | P | B | PB16 | LUZ2 | E | LND | DEL |  |
| P3ALL2D | ALL2 Purge Columns - PO issued | milestone | 0d | 2008-06-19 A | 2008-06-19 A | P3ALL2C, F2930 FF, F7900 FF | 100% |  | 264,344 | 264,344 | P3ALL2D | P3ALL2D | 860 | ALL2 | 00 | DC | 2DC8500 | 200 | 200 | 400 | P | LND | C2 | P | B | PB43 | LUZ2 | E | LND |  | 3A |
| P3ALL2L | ALL2 Purge Columns - Lead Time/Fabrication |  | 306d | 2008-06-19 A | 2009-04-23 A | P3ALL2D | 100% | TB26 - 2 - Manuf and Delivy |  |  | P3ALL2L | P3ALL2L | 860 | ALL2 | 00 | DC | 2DC8500 | 200 | 200 | 400 | P | LND | C2 | P | B | PB46 | LUZ2 | E | LND | DEL |  |
| P3A08D1 | A08 Vent/Bag Filter - PO issued (Engineering) | milestone | 0d | 2008-06-21 A | 2008-06-21 A | P3A08C FF, F2920 FF, F5740 FF, E3A0820 | 100% |  |  |  | P3A08D1 | P3A08D1 | 860 | A08 | 00 | DC | 2DC8560 | 200 | 200 | 400 | P | LND | C2 | P | B | PB83 | LUZ2 | S | LND |  | 3A |
| P3A08L | A08 Vent/Bag Filter - Lead Time/Fabrication |  | 939d | 2008-06-21 A | 2011-01-26 A | P3A08D1 | 100% | TB26 - 2 - Manuf and Delivy |  |  | P3A08L | P3A08L | 860 | A08 | 00 | DC | 2DC8560 | 200 | 200 | 400 | P | LND | C2 | P | B | PB86 | LUZ2 | E | LND | DEL |  |
| P3A16D1 | A16 Offgas C Filters - PO issued (Engineering) | milestone | 0d | 2008-06-21 A | 2008-06-21 A | E3A1620 FF, F5940 FF, F2920 FF | 100% |  |  |  | P3A16D1 | P3A16D1 | 860 | A16 | 00 | DC | 2DC8560 | 200 | 200 | 400 | P | LND | C2 | P | B | PB83 | LUZ2 | E | LND |  | 3A |
| P3A16L | A16 Offgas C Filters - Lead Time/Fabrication |  | 939d | 2008-06-21 A | 2011-01-26 A | P3A16D1 | 100% | TB26 - 2 - Manuf and Delivy |  |  | P3A16L | P3A16L | 860 | A16 | 00 | DC | 2DC8560 | 200 | 200 | 400 | P | LND | C2 | P | B | PB86 | LUZ2 | E | LND | DEL |  |
| F5240 | A07 R Fines Eductor - Bid tab Client appr. |  | 7d | 2008-06-23 A | 2008-07-01 A | E3A0730 | 100% |  |  |  | F5240 | F5240 | 860 | A07 | 00 |  | 2DC8640 | 200 | 200 | 400 | P | PMT | C2 | P | B | PB92 | LUZ2 | 1 | LND |  | 3A |
| P3ALL4C | ALL4 Silo's - Eval./Negotiation |  | 28d | 2008-06-25 A | 2008-08-01 A | E3ALL420 FF, F10050 SS | 100% |  |  |  | P3ALL4C | P3ALL4C | 860 | ALL4 | 00 | DC | 2DC9000 | 200 | 200 | 400 | P | LND | C2 | P | B | PB62 | LUZ2 | S | LND |  |  |
| P3A07D1 | A07 R Fines Eductor - PO issued (Engineering) | milestone | 0d | 2008-07-04 A | 2008-07-04 A | F5240 FF, F2920 FF, E3A0720 FF | 100% |  |  |  | P3A07D1 | P3A07D1 | 860 | A07 | 00 | DC | 2DC8640 | 200 | 200 | 400 | P | LND | C2 | P | B | PB93 | LUZ2 | E | LND |  | 3A |
| P3A07L | A07 R Fines Eductor - Lead Time/Fabrication |  | 352d | 2008-07-04 A | 2009-06-24 A | P3A07D1 | 100% | TB26 - 2 - Manuf and Delivy |  |  | P3A07L | P3A07L | 860 | A07 | 00 | DC | 2DC8640 | 200 | 200 | 400 | P | LND | C2 | P | B | PB93 | LUZ2 | E | LND | DEL |  |
| P3A11A | A11 Unloading Arms - Prepare/Issue RFQ |  | 7d | 2008-07-10 A | 2008-07-18 A | E3A1110 | 100% |  |  |  | P3A11A | P3A11A | 860 | A11 | 00 |  | 2KB4420 | 200 | 200 | 400 | P | LND | 0 | P | B | PB91 | LUZ2 | E | LND | DEV |  |
| P3A02AA | A02A Large Drums - Prepare/Issue RFQ |  | 3d | 2008-07-11 A | 2008-07-15 A | E3A02A10 | 100% |  |  |  | P3A02AA | P3A02AA | 860 | A02A | 00 |  | 2DC9450 | 200 | 200 | 400 | P | LND | 0 | P | B | PB11 | LUZ2 | E | LND | DEV |  |
| P3A02AB | A02A Large Drums - RFQ issued | milestone | 0d | 2008-07-16 A | 2008-07-16 A | P3A02AA FF | 100% |  | 22,730 | 22,730 | P3A02AB | P3A02AB | 860 | A02A | 00 |  | 2DC9450 | 200 | 200 | 400 | P | LND | 0 | P | B | PB11 | LUZ2 | E | LND | DEV |  |
| P3A11B | A11 Unloading Arms - RFQ issued | milestone | 0d | 2008-07-19 A | 2008-07-19 A | P3A11A FF | 100% |  | 7,202 | 7,202 | P3A11B | P3A11B | 860 | A11 | 00 |  | 2KB4420 | 200 | 200 | 400 | P | LND | 0 | P | B | PB91 | LUZ2 | E | LND | DEV |  |
| F10090 | ALL4 Silo's - Bid Tab Client Approval |  | 7d | 2008-07-23 A | 2008-07-31 A | P3ALL4C FF, E3ALL430 | 100% |  |  |  | F10090 | F10090 | 860 | ALL4 | 00 | DC | 2DC9000 | 200 | 200 | 400 | P | PMT | C2 | P | B | PB62 | LUZ2 | 1 | LND |  |  |
| F5390 | A04A R Overhead Co.- Vendor Bid for INEOS Review | milestone | 0d | 2008-07-23 A | 2008-07-23 A | F5260 | 100% |  |  |  | F5390 | F5390 | 860 | A04A | 00 |  | 2DC9110 | 200 | 200 | 400 | P | LND | C2 | P | B | PB12 | LUZ2 | 1 | LND |  | 3A |
| P3ALL4D1 | ALL4 Silo's - PO issued (Eng) | milestone | 0d | 2008-08-02 A | 2008-08-02 A | P3ALL4C FF, F10090 FF, F2930 FF | 100% |  |  |  | P3ALL4D1 | P3ALL4D1 | 860 | ALL4 | 00 | DC | 2DC9000 | 200 | 200 | 400 | P | LND | C2 | P | B | PB63 | LUZ2 | S | LND |  |  |
| P3ALL4L | ALL4 Silo's - Lead Time/Fabrication |  | 586d | 2008-08-02 A | 2010-03-17 A | P3ALL4D1, P3ALL4D2 FF | 100% | TB26 - 2 - Manuf and Delivy |  |  | P3ALL4L | P3ALL4L | 860 | ALL4 | 00 | DC | 2DC9000 | 200 | 200 | 400 | P | LND | C2 | P | B | PB66 | LUZ2 | E | LND | DEL |  |
| HPBALL4 | Silo Pck. (ALL4) PO/Fabr./Transport to Site | level of effort | 513d | 2008-08-04 A | 2010-08-20 A | P3ALL4L SS | 100% |  |  |  | HPBALL4 | HPBALL4 | 869 |  | 00 |  |  | 200 | 200 | 400 | E | LND | L2 | P | B | PB93 | LUZ2 | E | LND | DFA |  |
| P3A04AC | A04A R Overhead Cond. - Eval./Negotiation |  | 50d | 2008-08-07 A | 2008-10-16 A | F5310 | 100% |  |  |  | P3A04AC | P3A04AC | 860 | A04A | 00 | DC | 2DC9110 | 200 | 200 | 400 | P | LND | C2 | P | B | PB12 | LUZ2 | E | LND |  | 3A |
| P3A03A | A03 Catalyst Drum Roller - Prepare/Issue RFQ |  | 3d | 2008-09-01 A | 2008-09-03 A | E3A0310 | 100% |  |  |  | P3A03A | P3A03A | 860 | A03 | 00 |  | 2DC9630 | 200 | 200 | 400 | P | LND | 0 | P | B | PB91 | LUZ2 | E | LND | DEV |  |
| P3A03B | A03 Catalyst Drum Roller - RFQ issued | milestone | 0d | 2008-09-04 A | 2008-09-04 A | P3A03A FF | 100% |  | 3,365 | 3,365 | P3A03B | P3A03B | 860 | A03 | 00 |  | 2DC9630 | 200 | 200 | 400 | P | LND | 0 | P | B | PB91 | LUZ2 | E | LND | DEV |  |
| F5440 | A04A R Overhead Cond. - Bid tab Client appr. |  | 9d | 2008-09-23 A | 2008-10-06 A | E3A04A30, P3A04AC FF | 100% |  |  |  | F5440 | F5440 | 860 | A04A | 00 |  | 2DC9110 | 200 | 200 | 400 | P | PMT | C2 | P | B | PB12 | LUZ2 | 1 | LND |  | 3A |
| P3A08D2 | A08 Vent/Bag Filter - PO issued (Equipment) | milestone | 0d | 2008-09-30 A | 2008-09-30 A | P3A08D1 FF+30d | 100% |  | 242,800 | 242,800 | P3A08D2 | P3A08D2 | 860 | A08 | 00 | DC | 2DC8560 | 200 | 200 | 400 | P | LND | C2 | P | B | PB83 | LUZ2 | S | LND |  | 3A |
| P3A16D2 | A16 Offgas C Filters - PO issued (Equipment) | milestone | 0d | 2008-09-30 A | 2008-09-30 A | P3A16D1 FF+30d | 100% |  | 76,400 | 76,400 | P3A16D2 | P3A16D2 | 860 | A16 | 00 | DC | 2DC8560 | 200 | 200 | 400 | P | LND | C2 | P | B | PB83 | LUZ2 | E | LND |  | 3A |
| P3ALL4D2 | ALL4 Silo's - PO issued (Equip) | milestone | 0d | 2008-09-30 A | 2008-09-30 A | F2840, P3ALL4D1 FF | 100% |  | 774,580 | 774,580 | P3ALL4D2 | P3ALL4D2 | 860 | ALL4 | 00 | DC | 2DC9000 | 200 | 200 | 400 | P | LND | C2 | P | B | PB63 | LUZ2 | S | LND |  |  |
| P3A17A | A17 Teal S. C. Internal - Prepare/Issue RFQ |  | 5d | 2008-10-06 A | 2008-10-10 A | E3A1710 | 100% |  |  |  | P3A17A | P3A17A | 860 | A17 | 00 |  | 2DD8530 | 200 | 200 | 400 | P | LND | 0 | P | B | PB11 | LUZ2 | E | LND | DEV |  |
| P3A05D2 | A05 Offgas Cyclone&R - PO issued (Equipment) | milestone | 0d | 2008-10-07 A | 2008-10-07 A | P3A05D1 FF | 100% |  | 71,648.8 | 71,648.8 | P3A05D2 | P3A05D2 | 860 | A05 | 00 | DC | 2DC8590 | 200 | 200 | 400 | P | LND | C2 | P | B | PB13 | LUZ2 | S | LND |  | 3A |
| P3A07D2 | A07 R Fines Eductor - PO issued (Equipment) | milestone | 0d | 2008-10-07 A | 2008-10-07 A | P3A07D1 FF | 100% |  | 28,520 | 28,520 | P3A07D2 | P3A07D2 | 860 | A07 | 00 | DC | 2DC8640 | 200 | 200 | 400 | P | LND | C2 | P | B | PB93 | LUZ2 | E | LND |  | 3A |
| P3A17B | A17 Teal S. C. Internal - RFQ issued | milestone | 0d | 2008-10-11 A | 2008-10-11 A | P3A17A FF | 100% |  |  |  | P3A17B | P3A17B | 860 | A17 | 00 |  | 2DD8530 | 200 | 200 | 400 | P | LND | 0 | P | B | PB11 | LUZ2 | E | LND | DEV |  |
| P3A04AD | A04A R Overhead Cond. - PO issued | milestone | 0d | 2008-10-17 A | 2008-10-17 A | F2920 FF, F5440 FF, E3A04A20 FF | 100% |  | 395,400 | 395,400 | P3A04AD | P3A04AD | 860 | A04A | 00 | DC | 2DC9110 | 200 | 200 | 400 | P | LND | C2 | P | B | PB13 | LUZ2 | E | LND |  | 3A |
| P3A04AL | A04A R Overhead Cond. - Lead Time/Fabrication |  | 742d | 2008-10-17 A | 2010-11-05 A | P3A04AD | 100% | TB26 - 2 - Manuf and Delivy |  |  | P3A04AL | P3A04AL | 860 | A04A | 00 | DC | 2DC9110 | 200 | 200 | 400 | P | LND | C2 | P | B | PB16 | LUZ2 | E | LND | DEL |  |
| P3A02BA | A02B Polymer W.Basket - Prepare/Issue RFQ |  | 5d | 2008-11-11 A | 2008-11-17 A | E3A02B10 | 100% |  |  |  | P3A02BA | P3A02BA | 860 | A02B | 00 |  | 2DC9840 | 200 | 200 | 400 | P | LND | 0 | P | B | PB11 | LUZ2 | E | LND | DEV |  |
| P3A02BB | A02B Polymer W.Basket - RFQ issued | milestone | 0d | 2008-11-18 A | 2008-11-18 A | P3A02BA FF | 100% |  | 2,878.75 | 2,878.75 | P3A02BB | P3A02BB | 860 | A02B | 00 |  | 2DC9840 | 200 | 200 | 400 | P | LND | 0 | P | B | PB11 | LUZ2 | E | LND | DEV |  |
| P3A02AC | A02A Large Drums - Eval./Negotiation |  | 410d | 2008-11-26 A | 2010-07-19 A | E3A02A20 FF, P3A02AB | 100% |  |  |  | P3A02AC | P3A02AC | 860 | A02A | 00 |  | 2DC9450 | 200 | 200 | 400 | P | LND | 0 | P | B | PB12 | LUZ2 | E | LND |  |  |
| P3A06C | A06 Start-Up Heater/Condenser - Eval./Negotiation |  | 319d | 2008-11-26 A | 2010-03-08 A | P3A06B, E3A0620 FF | 100% |  |  |  | P3A06C | P3A06C | 860 | A06 | 00 |  | 2DD8530 | 200 | 200 | 400 | P | LND | 0 | P | B | PB22 | LUZ2 | E | LND |  |  |
| P3A01C | A01 Drums/Small Vessels - Eval./Negotiation |  | 318d | 2008-11-27 A | 2010-03-08 A | P3A01B, E3A0120 FF | 100% |  |  |  | P3A01C | P3A01C | 860 | A01 | 00 |  | 2DD8530 | 200 | 200 | 400 | P | LND | 0 | P | B | PB12 | LUZ2 | E | LND |  |  |
| P3A06AC | A06A Electrical Heater - Eval./Negotiation |  | 304d | 2009-01-06 A | 2010-03-19 A | P3A06AB, E3A06A20 FF | 100% |  |  |  | P3A06AC | P3A06AC | 860 | A06A | 00 |  | 2DC9080 | 200 | 200 | 400 | P | LND | 0 | P | B | PB22 | LUZ2 | E | LND |  |  |
| P3A11C | A11 Unloading Arms - Eval./Negotiation |  | 233d | 2009-02-10 A | 2010-01-14 A | P3A11B, E3A1120 FF | 100% |  |  |  | P3A11C | P3A11C | 860 | A11 | 00 |  | 2KB4420 | 200 | 200 | 400 | P | LND | 0 | P | B | PB92 | LUZ2 | E | LND |  |  |
| P3A13C | A13 Scales - Eval./Negotiation |  | 301d | 2009-02-18 A | 2010-04-30 A | P3A13B, E3A1320 FF | 100% |  |  |  | P3A13C | P3A13C | 860 | A13 | 00 |  | 2DC9060 | 200 | 200 | 400 | P | LND | 0 | P | B | PB92 | LUZ2 | E | LND |  |  |
| P3U22E | PU22 Vacuum System - Vendor Selection approval |  | 74d | 2009-02-26 A | 2009-06-16 A | P3U22F FF, P3U22F SS | 100% |  |  |  | P3U22E | P3U22E | 860 | PU22 | 00 |  | 2DC9170 | 200 | 200 | 400 | P | PMT | 0 | P | B | PJ32 | LUZ2 | P | LND |  |  |
| P3A02BC | A02B Polymer W.Basket - Eval./Negotiation |  | 358d | 2009-03-30 A | 2010-08-31 A | P3A02BB, E3A02B20 FF | 100% |  |  |  | P3A02BC | P3A02BC | 860 | A02B | 00 |  | 2DC9840 | 200 | 200 | 400 | P | LND | 0 | P | B | PB12 | LUZ2 | E | LND |  |  |
| P3ALL2X | ALL2 Purge Columns - Final Inspection |  | 6d | 2009-04-03 A | 2009-04-08 A | E3ALL260 FF+10d, P3ALL2L FF-14d | 100% | TB26 - 2 - Manuf and Delivy | 396,516 | 396,516 | P3ALL2X | P3ALL2X | 860 | ALL2 | 00 | DC | 2DC8500 | 200 | 200 | 400 | P | LND | C2 | P | B | PB47 | LUZ2 | S | LND |  |  |
| P3A04X | A04 R Overhead Separ. - Final Inspection |  | 4d | 2009-04-06 A | 2009-04-10 A | P3A04L FF-14d, E3A0460 FF+10d, A1KL1130E | 100% | TB26 - 2 - Manuf and Delivy | 193,107.6 | 193,107.6 | P3A04X | P3A04X | 860 | A04 | 00 | DC | 2DC8500 | 200 | 200 | 400 | P | LND | C2 | P | B | PB17 | LUZ2 | S | LND |  |  |
| P3A18A | A18 Flare Package - Prepare/Issue RFQ |  | 2d | 2009-05-28 A | 2009-05-29 A | E3A1810, ES100103 | 100% |  |  |  | P3A18A | P3A18A | 860 | A18 | 00 |  | 2DD0330 | 200 | 200 | 400 | P | LND | 0 | P | B | PB11 | LUZ2 | E | LND | DEV |  |
| P3A18B | A18 Flare Package - RFQ issued | milestone | 0d | 2009-05-29 A | 2009-05-29 A | P3A18A FF | 100% |  | 109,000 | 109,000 | P3A18B | P3A18B | 860 | A18 | 00 |  | 2DD0330 | 200 | 200 | 400 | P | LND | 0 | P | B | PB11 | LUZ2 | E | LND | DEV |  |
| P3A07X | A07 R Fines Eductor - Final Inspection |  | 5d | 2009-06-15 A | 2009-06-20 A | P3A07D2, E3A0760 FF+10d, P3A07L FF-5d | 100% | TB26 - 2 - Manuf and Delivy | 42,780 | 42,780 | P3A07X | P3A07X | 860 | A07 | 00 | DC | 2DC8640 | 200 | 200 | 400 | P | LND | C2 | P | B | PB97 | LUZ2 | S | LND |  |  |
| P3A01B1 | A01 Drums/Small Vessels - RFQ re-issued | milestone | 0d | 2009-06-29 A | 2009-06-29 A | P3A01B | 100% |  |  |  | P3A01B1 | P3A01B1 | 860 | A01 | 00 |  | 2DD8530 | 200 | 200 | 400 | P | LND | 0 | P | B | PB11 | LUZ2 | E | LND | DEV |  |
| P3A06B1 | A06 Start-Up Heater/Condenser - RFQ re-issued | milestone | 0d | 2009-06-29 A | 2009-06-29 A | P3A06B | 100% |  |  |  | P3A06B1 | P3A06B1 | 860 | A06 | 00 |  | 2DD8530 | 200 | 200 | 400 | P | LND | 0 | P | B | PB21 | LUZ2 | E | LND | DEV |  |
| P3A11F | A11 Unloading Arms - Bid tab Client appr. |  | 20d | 2009-07-03 A | 2009-07-30 A | E3A1130 | 100% |  |  |  | P3A11F | P3A11F | 860 | A11 | 00 |  | 2KB4420 | 200 | 200 | 400 | P | PMT | 0 | P | B | PB12 | LUZ2 | E | LND |  |  |
| P3A12A | A12 Overhead Cranes - Prepare/Issue RFQ |  | 5d | 2009-08-03 A | 2009-08-07 A | E3A1210 | 100% |  |  |  | P3A12A | P3A12A | 860 | A12 | 00 |  | 2KB4740 | 200 | 200 | 400 | P | LND | 0 | P | B | PB91 | LUZ2 | E | LND | DEV |  |
| P3A12B | A12 Overhead Cranes - RFQ issued | milestone | 0d | 2009-08-07 A | 2009-08-07 A | P3A12A FF | 100% |  |  |  | P3A12B | P3A12B | 860 | A12 | 00 |  | 2KB4740 | 200 | 200 | 400 | P | LND | 0 | P | B | PB91 | LUZ2 | S | LND | DEV |  |
| P3A00A | A00 Mechanical Subcontract - Tender issued | milestone | 0d | 2009-08-17 A | 2009-08-17 A | P3C00B FF+65d, P3C01A FF+5d | 100% |  |  |  | P3A00A | P3A00A | 860 | A00 | 00 |  | 2MD6880 | 200 | 200 | 400 | P | LND | 0 | P | B | PM11 | LUZ2 | SS | LND | DEV |  |
| P3A00H | A00 Mechanical Subcontract - Bid preparation |  | 78d | 2009-08-18 A | 2009-12-04 A | P3A00A | 100% |  |  |  | P3A00H | P3A00H | 860 | A00 | 00 |  | 2MD6880 | 200 | 200 | 400 | P | LND | 0 | P | B | PM11 | LUZ2 | SS | LND | DEV |  |
| HPB30 | Static Eqpt - Remaining Equipment PO's |  | 233d | 2009-09-28 A | 2010-08-31 A | P3A13D FF, P3A03D FF, P3A06AD FF, P3A02CD FF, P3A02BD FF, P3A11D FF | 100% |  |  |  | HPB30 | HPB30 | 869 |  | 00 |  |  | 200 | 200 | 400 | E | LND | L2 | P | B | PB93 | LUZ2 | P | LND | DFA |  |
| P3A00C | A00 Mechanical Subcontract - Evaluation Bids / questionnaire |  | 10d | 2009-12-07 A | 2009-12-18 A | P3A00H | 100% |  |  |  | P3A00C | P3A00C | 860 | A00 | 00 |  | 2MD6880 | 200 | 200 | 400 | P | LND | 0 | P | B | PM11 | LUZ2 | SS | LND | DEV |  |
| A1010240 | A00 Mechanical Subcontract - Negotiations delayed by client !! |  | 250d | 2009-12-14 A | 2010-12-09 A | P3A00C FS+6d | 100% |  |  |  | A1010240 | A1010240 | 860 | A00 | 00 |  | 2MD6880 | 200 | 200 | 400 | P | LND | 0 | P | B | PM11 | LUZ2 | mi | LND | DEV |  |
| P3A12C | A12 Overhead Cranes - Eval./Negotiation -delayed by client !!!!!!! |  | 354d | 2009-12-14 A | 2011-05-06 A | E3A1220 FF | 100% |  |  |  | P3A12C | P3A12C | 860 | A12 | 00 |  | 2KB4740 | 200 | 200 | 400 | P | LND | 0 | P | B | PB12 | LUZ2 | S | LND |  |  |
| IMS-P-000040 | DCE - Finish Purchasing Activities (last PO placed) | level of effort | 40d | 2009-12-18 A | 2010-01-29 A | P3M16D, P3M01AD, P3U07D | 100% | TB26 - 2 - Manuf and Delivy |  |  | IMS-P-000040 | IMS-P-000040 | 860 |  | 00 |  |  | 200 | 200 | 400 | P | LND | 0 | P | B | PB16 | LUZ2 | P | IMS | DEL |  |
| IMS-P-000060 | Other Equipment - Finish Purchasing Activities (last PO placed) | level of effort | 531d | 2009-12-19 A | 2011-06-10 A | P3U15D2, P3A18D | 100% | TB26 - 2 - Manuf and Delivy |  |  | IMS-P-000060 | IMS-P-000060 | 860 |  | 00 |  |  | 200 | 200 | 400 | P | LND | 0 | P | B | PB16 | LUZ2 | P | IMS | DEL |  |
| P3A17C | A17 Teal S. C. Internal - Eval./Negotiation (w.Press.Eqpt) |  | 51d | 2009-12-22 A | 2010-03-08 A | E3A1720 FF, P3A17B | 100% |  |  |  | P3A17C | P3A17C | 860 | A17 | 00 |  | 2DD8530 | 200 | 200 | 400 | P | LND | 0 | P | B | PB12 | LUZ2 | E | LND |  |  |
| P3A03C | A03 Catalyst Drum Roller - Eval./Negotiation |  | 43d | 2010-01-04 A | 2010-03-03 A | E3A0320 FF, P3A03B | 100% |  |  |  | P3A03C | P3A03C | 860 | A03 | 00 |  | 2DC9630 | 200 | 200 | 400 | P | LND | 0 | P | B | PB92 | LUZ2 | E | LND |  |  |
| P3A02CA | A02C Instrument Air Vessels - Prepare/Issue RFQ |  | 5d | 2010-01-11 A | 2010-01-15 A | E3A02C10 | 100% |  |  |  | P3A02CA | P3A02CA | 860 | A02C | 00 |  | 2DD8530 | 200 | 200 | 400 | P | LND | 0 | P | B | PB11 | LUZ2 | E | LND | DEV |  |
| P3A11D | A11 Unloading Arms - PO issued | milestone | 0d | 2010-01-14 A | 2010-01-14 A | P3A11C FF, E3A1120, P3A11F | 100% |  | 28,808 | 28,808 | P3A11D | P3A11D | 860 | A11 | 00 |  | 2KB4420 | 200 | 200 | 400 | P | LND | 0 | P | B | PB93 | LUZ2 | E | LND |  |  |
| P3A11L | A11 Unloading Arms - Lead Time/Fabrication |  | 304d | 2010-01-15 A | 2010-11-15 A | P3A11D | 100% | TB26 - 2 - Manuf and Delivy |  |  | P3A11L | P3A11L | 860 | A11 | 00 |  | 2KB4420 | 200 | 200 | 400 | P | LND | 0 | P | B | PB96 | LUZ2 | E | LND | DEL |  |
| P3A02CB | A02C Instrument Air Vessels - RFQ issued | milestone | 0d | 2010-01-15 A | 2010-01-15 A | P3A02CA FF | 100% |  | 6,200 | 6,200 | P3A02CB | P3A02CB | 860 | A02C | 00 |  | 2DD8530 | 200 | 200 | 400 | P | LND | 0 | P | B | PB11 | LUZ2 | E | LND | DEV |  |
| P3A00H1 | A00 Mechanical Subcontract - Preparation of rev. Bid's |  | 131d | 2010-01-18 A | 2010-07-23 A | A1010240, P3A00C | 100% |  |  |  | P3A00H1 | P3A00H1 | 860 | A00 | 00 |  | 2MD6880 | 200 | 200 | 400 | P | LND | 0 | P | B | PM11 | LUZ2 | SS | LND | DEV |  |
| P3A02CC | A02C Instrument Air Vessels - Eval./Negotiation |  | 36d | 2010-01-18 A | 2010-03-08 A | E3A02C20 FF, P3A02CB | 100% |  |  |  | P3A02CC | P3A02CC | 860 | A02C | 00 |  | 2DD8530 | 200 | 200 | 400 | P | LND | 0 | P | B | PB12 | LUZ2 | E | LND |  |  |

Notes:
- P3A04D: Expenses: 900A 128738
- P3ALL2D: Expenses: 900A 264344
- P3A07L: P3 Activity Log Info: will / be storaged by packager
- P3A02AB: Expenses: 900A 22730
- P3A11B: Expenses: 900A 7202
- HPBALL4: UDF_Actictity Name (Russia): Комплект силосов (ALL4), заказ на поставку/изготовление/транспортировка на площадку
- P3A03B: Expenses: 900A 3365
- P3A08D2: Expenses: 900A 242800
- P3A16D2: Expenses: 900A 76400
- P3ALL4D2: Expenses: 900A 774580
- P3A05D2: Expenses: 900A 71648.8
- P3A07D2: Expenses: 900A 28520
- P3A17B: Expenses: 900A 0
- P3A04AD: Expenses: 900A 395400
- P3A02BB: Expenses: 900A 2878.75
- P3ALL2X: Expenses: 900A 396516
- P3A04X: Expenses: 900A 193108
- P3A18B: Expenses: 900A 109000
- P3A07X: Expenses: 900A 42780
- P3A12B: Expenses: 900A 0
- HPB30: UDF_Actictity Name (Russia): Статическое оборудование - Оставшиеся заказы на поставку
- P3A12C: Customer Problem: 11.01.11- B. RoЯberg: PO expected earliest 02FEB11, / because client add supplier optimkran to vendor list, audit performed / 10./11.01.11 by Ms. Schilka (5 month delay!) -Mr. Kern
- P3A11D: Expenses: 900A 28808
- P3A02CB: Expenses: 900A 6200

| ID | Activity | Type | Duration | Start | Finish | Predecessors | Complete | Remaining | Total float | Free float | Calendar | Cost | Actual cost | UDF_SAVE ACTID | UDF_SAVE ACT ID | Department | Type of Work | Constr. Area | Inquiry/Order No | PMT-Area | PMT-Schedule Org | PMT-Discipline | PMT-Phase | PMT-Respons. | Zeigen/n. Zeigen | WBS Phase | WBS Discipline | WBS Type of Work | WBS Objects | IMS | UPT | Pro Unit/DocCode | PMT-Doc. Type |
| --- | --- | --- | --- | --- | --- | --- | --- | --- | --- | --- | --- | --- | --- | --- | --- | --- | --- | --- | --- | --- | --- | --- | --- | --- | --- | --- | --- | --- | --- | --- | --- | --- | --- |
| P3A17F | A17 Teal S. C. Internal - Bid tab Client appr. |  | 5d | 2010-02-03 A | 2010-02-09 A | E3A1730 | 100% |  |  |  |  |  |  | P3A17F | P3A17F | 860 | A17 | 00 | 2DD8530 | 200 | 200 | 400 | P | PMT | 0 | P | B | PB12 | LUZ2 | E | PMT |  |  |
| P3ALL4G | ALL4 Gost R Certificate to russ. customs | milestone | 0d | 2010-02-06 A | 2010-02-06 A | P3ALL4N1 FF-85d | 100% |  |  |  | TB26 - 2 - Manuf and Delivy |  |  | P3ALL4G | P3ALL4G | 860 | ALL4 | 00 | 2DC9000 | 200 | 200 | 400 | P | LND | 0 | P | B | PB67 | LUZ2 | E | LND |  |  |
| P3A13F | A13 Scales - Bid tab Client appr. |  | 46d | 2010-02-08 A | 2010-04-14 A | E3A1330 | 100% |  |  |  |  |  |  | P3A13F | P3A13F | 860 | A13 | 00 | 2DC9060 | 200 | 200 | 400 | P | PMT | 0 | P | B | PB12 | LUZ2 | E | PMT |  |  |
| P3A01F | A01 Drums/Small Vessels - Bid tab Client appr. |  | 5d | 2010-02-25 A | 2010-03-03 A | E3A0130 | 100% |  |  |  |  |  |  | P3A01F | P3A01F | 860 | A01 | 00 | 2DD8530 | 200 | 200 | 400 | P | PMT | 0 | P | B | PB12 | LUZ2 | E | PMT |  |  |
| P3A02CF | A02C Instrument Air Vessels - Bid tab Client appr. |  | 4d | 2010-02-26 A | 2010-03-03 A | E3A02C30 | 100% |  |  |  |  |  |  | P3A02CF | P3A02CF | 860 | A02C | 00 | 2DD8530 | 200 | 200 | 400 | P | PMT | 0 | P | B | PB12 | LUZ2 | E | LND |  |  |
| P3ALL4X | ALL4 Silo's - Final Inspection |  | 3d | 2010-03-01 A | 2010-03-03 A | P3ALL4L FF-10d, E3ALL460 FF+10d, P3ALL4D2 | 100% |  |  |  | TB26 - 2 - Manuf and Delivy | 1,161,870 | 1,161,870 | P3ALL4X | P3ALL4X | 860 | ALL4 | 00 | 2DC9000 | 200 | 200 | 400 | P | LND | C2 | P | B | PB67 | LUZ2 | E | LND | DC |  |
| HPB20 | Static Eqpt - Remaining Engineering PO's |  | 88d | 2010-03-03 A | 2010-07-08 A | P3A06D FF, P3A03D, P3A02AD FF, P3A01D FF | 100% |  |  |  |  |  |  | HPB20 | HPB20 | 869 |  | 00 |  | 200 | 200 | 400 | E | LND | L2 | P | B | PB93 | LUZ2 | P | LND |  | DFA |
| P3A03D | A03 Catalyst Drum Roller - PO issued | milestone | 0d | 2010-03-03 A | 2010-03-03 A | E3A0330 FF, F2940 FF, P3A03C FF, IMS-P-000060 FF | 100% |  |  |  |  | 13,460 | 13,460 | P3A03D | P3A03D | 860 | A03 | 00 | 2DC9630 | 200 | 200 | 400 | P | LND | 0 | P | B | PB93 | LUZ2 | P | LND |  |  |
| HPBA03 | Cat.DrumRoller (A03) PO/Fabr./Transport to Site | level of effort | 197d | 2010-03-04 A | 2010-12-10 A | P3A03L SS | 100% |  |  |  |  |  |  | HPBA03 | HPBA03 | 869 |  | 00 |  | 200 | 200 | 400 | E | LND | L2 | P | B | PB93 | LUZ2 | E | LND |  | DFA |
| P3A03L | A03 Catalyst Drum Roller - Lead Time/Fabrication |  | 200d | 2010-03-04 A | 2010-09-20 A | P3A03D | 100% |  |  |  | TB26 - 2 - Manuf and Delivy |  |  | P3A03L | P3A03L | 860 | A03 | 00 | 2DC9630 | 200 | 200 | 400 | P | LND | 0 | P | B | PB96 | LUZ2 | E | LND |  | DEL |
| P3A01D | A01 Drums/Small Vessels - PO issued | milestone | 0d | 2010-03-08 A | 2010-03-08 A | E3A0130 FF, F2940 FF, P3A01F FF, P3A01B1, P3A01C FF | 100% |  |  |  |  | 82,032 | 82,032 | P3A01D | P3A01D | 860 | A01 | 00 | 2DD8530 | 200 | 200 | 400 | P | LND | 0 | P | B | PB13 | LUZ2 | P | LND |  |  |
| P3A02CD | A02C Instrument Air Vessels - PO issued | milestone | 0d | 2010-03-08 A | 2010-03-08 A | P3A02CC FF, P3A02CF FF, E3A02C30 FF | 100% |  |  |  |  | 24,800 | 24,800 | P3A02CD | P3A02CD | 860 | A02C | 00 | 2DD8530 | 200 | 200 | 400 | P | LND | 0 | P | B | PB13 | LUZ2 | E | LND |  |  |
| P3A06D | A06 Start-Up Heater/Condenser - PO issued | milestone | 0d | 2010-03-08 A | 2010-03-08 A | P3A06B1, F2940 FF, E3A0615, P3A06C FF | 100% |  |  |  |  | 37,280 | 37,280 | P3A06D | P3A06D | 860 | A06 | 00 | 2DD8530 | 200 | 200 | 400 | P | LND | 0 | P | B | PB23 | LUZ2 | P | LND |  |  |
| P3A17D | A17 Teal S. C. Internal - PO issued (w.Press.Eqpt) | milestone | 0d | 2010-03-08 A | 2010-03-08 A | E3A1730 FF, F2940 FF, P3A17C FF, P3A17F FF | 100% |  |  |  |  |  |  | P3A17D | P3A17D | 860 | A17 | 00 | 2DD8530 | 200 | 200 | 400 | P | LND | 0 | P | B | PB13 | LUZ2 | P | LND |  |  |
| HPBA01 | Pressure Eqpt. (A01) PO/Fabr./Transport to Site | level of effort | 406d | 2010-03-09 A | 2011-10-07 | P3A01L SS |  | 26d | 4d | 0d |  |  |  | HPBA01 | HPBA01 | 869 |  | 00 |  | 200 | 200 | 400 | E | LND | L2 | P | B | PB93 | LUZ2 | E | LND |  | DFA |
| HPBA02B | Pol.W.Basket (A02B) PO/Fabr./Transport to Site | level of effort | 393d | 2010-03-09 A | 2011-09-19 | P3A02CL SS, P3A02BL SS |  | 13d | 43d | 0d |  |  |  | HPBA02B | HPBA02B | 869 |  | 00 |  | 200 | 200 | 400 | E | LND | L2 | P | B | PB93 | LUZ2 | E | LND |  | DFA |
| HPBA06 | Start up Heater (A06) PO/Fabr./Transport to Site | level of effort | 406d | 2010-03-09 A | 2011-10-07 | P3A06L SS |  | 26d | -60d | 0d |  |  |  | HPBA06 | HPBA06 | 869 |  | 00 |  | 200 | 200 | 400 | E | LND | L2 | P | B | PB93 | LUZ2 | E | LND |  | DFA |
| HPBA17 | Col.Internals (A17) PO/Fabr./Transport to Site | level of effort | 406d | 2010-03-09 A | 2011-10-07 | P3A18L SS, P3A17L SS |  | 26d | 425.5d | 0d |  |  |  | HPBA17 | HPBA17 | 869 |  | 00 |  | 200 | 200 | 400 | E | LND | L2 | P | B | PB93 | LUZ2 | E | LND |  | DFA |
| P3A01L | A01 Drums/Small Vessels - Lead Time/Fabrication |  | 353d | 2010-03-09 A | 2011-02-28 A | P3A01D | 100% |  |  |  | TB26 - 2 - Manuf and Delivy |  |  | P3A01L | P3A01L | 860 | A01 | 00 | 2DD8530 | 200 | 200 | 400 | P | LND | 0 | P | B | PB16 | LUZ2 | E | LND |  | DEL |
| P3A02CL | A02C Instrument Air Vessels - Lead Time/Fabrication |  | 353d | 2010-03-09 A | 2011-02-28 A | P3A02CD | 100% |  |  |  | TB26 - 2 - Manuf and Delivy |  |  | P3A02CL | P3A02CL | 860 | A02C | 00 | 2DD8530 | 200 | 200 | 400 | P | LND | 0 | P | B | PB16 | LUZ2 | E | LND |  | DEL |
| P3A06L | A06 Start-Up Heater/Condenser - Lead Time/Fabrication |  | 353d | 2010-03-09 A | 2011-02-28 A | P3A06D | 100% |  |  |  | TB26 - 2 - Manuf and Delivy |  |  | P3A06L | P3A06L | 860 | A06 | 00 | 2DD8530 | 200 | 200 | 400 | P | LND | 0 | P | B | PB26 | LUZ2 | E | LND |  | DEL |
| P3A17L | A17 Teal S. C. Internal - Lead Time/Fabrication |  | 353d | 2010-03-09 A | 2011-02-28 A | P3A17D | 100% |  |  |  | TB26 - 2 - Manuf and Delivy |  |  | P3A17L | P3A17L | 860 | A17 | 00 | 2DD8530 | 200 | 200 | 400 | P | LND | 0 | P | B | PB16 | LUZ2 | E | LND |  | DEL |
| P3ALL4M1 | ALL4 Silo's - Goods delivered FOB 1st LOT | milestone | 0d | 2010-03-17 A | 2010-03-17 A | P3ALL4L FF | 100% |  |  |  | TB26 - 2 - Manuf and Delivy | 580,935 | 580,935 | P3ALL4M1 | P3ALL4M1 | 860 | ALL4 | 00 | 2DC9000 | 200 | 200 | 400 | P | LND | C2 | P | B | PB68 | LUZ2 | E | LND | DC |  |
| P3ALL4M2 | ALL4 Silo's - Goods delivered FOB 2nd LOT | milestone | 0d | 2010-03-17 A | 2010-03-17 A | P3ALL4L | 100% |  |  |  | TB26 - 2 - Manuf and Delivy |  |  | P3ALL4M2 | P3ALL4M2 | 860 | ALL4 | 00 | 2DC9000 | 200 | 200 | 400 | P | LND | C2 | P | B | PB68 | LUZ2 | E | LND | DC |  |
| P3A06AD | A06A Electrical Heater - PO issued | milestone | 0d | 2010-03-19 A | 2010-03-19 A | P3A06AC, E3A06A20 FF, E3A06A15 | 100% |  |  |  |  | 15,044 | 15,044 | P3A06AD | P3A06AD | 860 | A06A | 00 | 2DC9080 | 200 | 200 | 400 | P | LND | 0 | P | B | PB23 | LUZ2 | P | LND |  |  |
| P3A06AL | A06A Electrical Heater - Lead Time/Fabrication |  | 194d | 2010-03-20 A | 2010-09-30 A | P3A06AD | 100% |  |  |  | TB26 - 2 - Manuf and Delivy |  |  | P3A06AL | P3A06AL | 860 | A06A | 00 | 2DC9080 | 200 | 200 | 400 | P | LND | 0 | P | B | PB26 | LUZ2 | E | LND |  | DEL |
| HPBA06A | Nitrogen Heater(A06A) PO/Fabr./Transport to Site | level of effort | 313d | 2010-03-22 A | 2011-06-10 A | P3A06AL SS | 100% |  |  |  |  |  |  | HPBA06A | HPBA06A | 869 |  | 00 |  | 200 | 200 | 400 | E | LND | L2 | P | B | PB93 | LUZ2 | E | LND |  | DFA |
| P3A13D | A13 Scales - PO issued | milestone | 0d | 2010-04-30 A | 2010-04-30 A | E3A1330 FF, P3A13C FF, P3A13F FF | 100% |  |  |  |  | 47,443 | 47,443 | P3A13D | P3A13D | 860 | A13 | 00 | 2DC9060 | 200 | 200 | 400 | P | LND | 0 | P | B | PB93 | LUZ2 | E | LND |  |  |
| P3A13L | A13 Scales - Lead Time/Fabrication |  | 161d | 2010-05-02 A | 2010-10-09 A | P3A13D | 100% |  |  |  | TB26 - 2 - Manuf and Delivy |  |  | P3A13L | P3A13L | 860 | A13 | 00 | 2DC9060 | 200 | 200 | 400 | P | LND | 0 | P | B | PB96 | LUZ2 | E | LND |  | DEL |
| HPBA13 | Scales (A13) PO/Fabr./Transport to Site | level of effort | 148d | 2010-05-03 A | 2010-11-29 A | P3A13L SS | 100% |  |  |  |  |  |  | HPBA13 | HPBA13 | 869 |  | 00 |  | 200 | 200 | 400 | E | LND | L2 | P | B | PB93 | LUZ2 | E | LND |  | DFA |
| P3A04M | A04 R Overhead Sep. - Goods delivered FOB Korea | milestone | 0d | 2010-05-04 A | 2010-05-04 A | P3A04L FF+10d | 100% |  |  |  | TB26 - 2 - Manuf and Delivy | 96,553.8 | 96,553.8 | P3A04M | P3A04M | 860 | A04 | 00 | 2DC8500 | 200 | 200 | 400 | P | LND | C2 | P | B | PB18 | LUZ2 | E | LND | DC |  |
| P3ALL2M | ALL2 Purge Columns - Goods delivered FOB Korea | milestone | 0d | 2010-05-04 A | 2010-05-04 A | P3ALL2L FF+10d | 100% |  |  |  | TB26 - 2 - Manuf and Delivy | 198,258 | 198,258 | P3ALL2M | P3ALL2M | 860 | ALL2 | 00 | 2DC8500 | 200 | 200 | 400 | P | LND | C2 | P | B | PB48 | LUZ2 | E | LND | DC |  |
| P3A04N | A04 R Overhead Separ. - Transport to Site |  | 113d | 2010-05-05 A | 2010-08-25 A | P3A04X, P3A04M, P3A04L | 100% |  |  |  | TB26 - 2 - Manuf and Delivy |  |  | P3A04N | P3A04N | 860 | A04 | 00 | 2DC8500 | 200 | 200 | 400 | P | LND | C2 | P | B | PB18 | LUZ2 | E | LND | DC |  |
| P3A04N1 | A04 R Overhead Sep. - Shipm. Korea Port-Antwerpe |  | 40d | 2010-05-05 A | 2010-06-13 A | P3A04M | 100% |  |  |  | TB26 - 2 - Manuf and Delivy |  |  | P3A04N1 | P3A04N1 | 860 | A04 | 00 | 2DC8500 | 200 | 200 | 400 | P | LND | C2 | P | B | PB18 | LUZ2 | E | LND | DC |  |
| P3ALL2N | ALL2 Purge Columns - Transport to Site |  | 113d | 2010-05-05 A | 2010-08-25 A | P3ALL2X, P3ALL2M, P3ALL2L | 100% |  |  |  | TB26 - 2 - Manuf and Delivy |  |  | P3ALL2N | P3ALL2N | 860 | ALL2 | 00 | 2DC8500 | 200 | 200 | 400 | P | LND | C2 | P | B | PB48 | LUZ2 | E | LND | DC |  |
| P3ALL2N1 | ALL2 Purge Columns - Shipm. Korea Port Antwerpen |  | 40d | 2010-05-05 A | 2010-06-13 A | P3ALL2M | 100% |  |  |  | TB26 - 2 - Manuf and Delivy |  |  | P3ALL2N1 | P3ALL2N1 | 860 | ALL2 | 00 | 2DC8500 | 200 | 200 | 400 | P | LND | C2 | P | B | PB48 | LUZ2 | E | LND | DC |  |
| P3ALL2G | ALL2 Gost R Certificate to russ. customs | milestone | 0d | 2010-05-10 A | 2010-05-10 A | P3ALL2N FF-90d | 100% |  |  |  | TB26 - 2 - Manuf and Delivy |  |  | P3ALL2G | P3ALL2G | 860 | ALL2 | 00 | 2DC8500 | 200 | 200 | 400 | P | LND | 0 | P | B | PB48 | LUZ2 | E | LND |  |  |
| P3A02AF | A02A Large Drums - Bid tab Client appr. |  | 8d | 2010-05-26 A | 2010-06-04 A | E3A02A30 | 100% |  |  |  |  |  |  | P3A02AF | P3A02AF | 860 | A02A | 00 | 2DC9450 | 200 | 200 | 400 | P | PMT | 0 | P | B | PB12 | LUZ2 | E | PMT |  |  |
| P3A04G | A04 Gost R Certificate to russ. customs | milestone | 0d | 2010-06-04 A | 2010-06-04 A | P3A04N FF-90d | 100% |  |  |  | TB26 - 2 - Manuf and Delivy |  |  | P3A04G | P3A04G | 860 | A04 | 00 | 2DC8500 | 200 | 200 | 400 | P | LND | 0 | P | B | PB18 | LUZ2 | E | LND |  |  |
| P3A05G | A05 Gost R Certificate to russ. customs | milestone | 0d | 2010-06-11 A | 2010-06-11 A | P3A05N FF-90d | 100% |  |  |  | TB26 - 2 - Manuf and Delivy |  |  | P3A05G | P3A05G | 860 | A05 | 00 | 2DC8590 | 200 | 200 | 400 | P | LND | 0 | P | B | PB18 | LUZ2 | E | LND |  |  |
| P3ALL4N1 | ALL4 Silo's - Transport to Site 1st LOT - delays customs code by client !, customs clearance since 09.07 on hold |  | 74d | 2010-06-11 A | 2010-08-23 A | P3ALL4X, P3ALL4L SS, P3ALL4M1 | 100% |  |  |  | TB26 - 2 - Manuf and Delivy |  |  | P3ALL4N1 | P3ALL4N1 | 860 | ALL4 | 00 | 2DC9000 | 200 | 200 | 400 | P | LND | C2 | P | B | PB68 | LUZ2 | E | LND | DC |  |
| P3A04N2 | A04 R Overhead Sep. - Shipm. Antw.-Archangelsk |  | 30d | 2010-06-14 A | 2010-07-13 A | P3A04N1 | 100% |  |  |  | TB26 - 2 - Manuf and Delivy |  |  | P3A04N2 | P3A04N2 | 860 | A04 | 00 | 2DC8500 | 200 | 200 | 400 | P | LND | C2 | P | B | PB18 | LUZ2 | E | LND | DC |  |
| P3ALL2N2 | ALL2 Purge Columns - Ship Antwerpen-Archangelsk |  | 30d | 2010-06-14 A | 2010-07-13 A | P3ALL2N1 | 100% |  |  |  | TB26 - 2 - Manuf and Delivy |  |  | P3ALL2N2 | P3ALL2N2 | 860 | ALL2 | 00 | 2DC8500 | 200 | 200 | 400 | P | LND | C2 | P | B | PB48 | LUZ2 | E | LND | DC |  |
| P3ALL4N2 | ALL4 Silo's - Transport to Site 2nd LOT - delays customs code by client !, customs clearance since 09.07 on hold |  | 58d | 2010-06-18 A | 2010-08-14 A | P3ALL4M2, P3ALL4N1 SS | 100% |  |  |  | TB26 - 2 - Manuf and Delivy |  |  | P3ALL4N2 | P3ALL4N2 | 860 | ALL4 | 00 | 2DC9000 | 200 | 200 | 400 | P | LND | C2 | P | B | PB68 | LUZ2 | E | LND | DC |  |
| P3A05X | A05 Offgas Cyclone&R - Final Inspection |  | 1d | 2010-06-23 A | 2010-06-23 A | P3A05L FF-7d, E3A0560 FF+10d, P3A05D2 | 100% |  |  |  | TB26 - 2 - Manuf and Delivy | 107,473.2 | 107,473.2 | P3A05X | P3A05X | 860 | A05 | 00 | 2DC8590 | 200 | 200 | 400 | P | LND | C2 | P | B | PB17 | LUZ2 | E | LND | DC |  |
| P3ALL4N3 | ALL4 Silo's - Custom Clearance Period LOT 1 +2 customs clearance since 09.07 on hold |  | 46d | 2010-07-09 A | 2010-08-23 A | P3ALL4N1 FF, P3ALL4N2 FF | 100% |  |  |  | TB26 - 2 - Manuf and Delivy |  |  | P3ALL4N3 | P3ALL4N3 | 860 | ALL4 | 00 | 2DC9000 | 200 | 200 | 400 | P | LND | C2 | P | B | PB68 | LUZ2 | E | LND | DC |  |
| P3A05M | A05 Offgas Cyclone&R - Goods delivered FOB | milestone | 0d | 2010-07-10 A | 2010-07-10 A | P3A05L FF+10d | 100% |  |  |  | TB26 - 2 - Manuf and Delivy | 53,736.6 | 53,736.6 | P3A05M | P3A05M | 860 | A05 | 00 | 2DC8590 | 200 | 200 | 400 | P | LND | C2 | P | B | PB18 | LUZ2 | E | LND | DC |  |
| P3A07G | A07 Gost R Certificate to russ. customs | milestone | 0d | 2010-07-12 A | 2010-07-12 A | P3A07N FF-90d | 100% |  |  |  | TB26 - 2 - Manuf and Delivy |  |  | P3A07G | P3A07G | 860 | A07 | 00 | 2DC8640 | 200 | 200 | 400 | P | LND | 0 | P | B | PB98 | LUZ2 | E | LND |  |  |
| P3A04N3 | A04 R Overhead Sep. - Shipm. Archangelsk-Tobolsk |  | 28d | 2010-07-14 A | 2010-08-10 A | P3A04N2 | 100% |  |  |  | TB26 - 2 - Manuf and Delivy |  |  | P3A04N3 | P3A04N3 | 860 | A04 | 00 | 2DC8500 | 200 | 200 | 400 | P | LND | C2 | P | B | PB18 | LUZ2 | E | LND | DC |  |
| P3ALL2N3 | ALL2 Purge Columns - Ship Archangelsk-Tobolsk |  | 28d | 2010-07-14 A | 2010-08-10 A | P3ALL2N1, P3ALL2N2 | 100% |  |  |  | TB26 - 2 - Manuf and Delivy |  |  | P3ALL2N3 | P3ALL2N3 | 860 | ALL2 | 00 | 2DC8500 | 200 | 200 | 400 | P | LND | C2 | P | B | PB48 | LUZ2 | E | LND | DC |  |
| P3A02AD | A02A Large Drums - PO issued | milestone | 0d | 2010-07-19 A | 2010-07-19 A | P3A02AC FF, P3A02AF FF, E3A02A30 FF | 100% |  |  |  |  | 90,920 | 90,920 | P3A02AD | P3A02AD | 860 | A02A | 00 | 2DC9450 | 200 | 200 | 400 | P | LND | 0 | P | B | PB13 | LUZ2 | P | LND |  |  |
| HPBA02A | Flare Drum (A02A) PO/Fabr./Transport to Site | level of effort | 189d | 2010-07-20 A | 2011-04-13 A | P3A02AL SS | 100% |  |  |  |  |  |  | HPBA02A | HPBA02A | 869 |  | 00 |  | 200 | 200 | 400 | E | LND | L2 | P | B | PB93 | LUZ2 | E | LND |  | DFA |
| P3A02AL | A02A Large Drums - Lead Time/Fabrication |  | 252d | 2010-07-20 A | 2011-03-31 A | P3A02AD | 100% |  |  |  | TB26 - 2 - Manuf and Delivy |  |  | P3A02AL | P3A02AL | 860 | A02A | 00 | 2DC9450 | 200 | 200 | 400 | P | LND | 0 | P | B | PB16 | LUZ2 | E | LND |  | DEL |
| P3A04N5 | A04 R Overhead Separ. - Custom Clearance Period |  | 15d | 2010-08-11 A | 2010-08-25 A | P3A04N3 | 100% |  |  |  | TB26 - 2 - Manuf and Delivy |  |  | P3A04N5 | P3A04N5 | 860 | A04 | 00 | 2DC8500 | 200 | 200 | 400 | P | LND | C2 | P | B | PB18 | LUZ2 | E | LND | DC |  |
| P3ALL2N5 | ALL2 Purge Columns - Custom Clearance Period |  | 15d | 2010-08-11 A | 2010-08-25 A | P3ALL2N3 | 100% |  |  |  | TB26 - 2 - Manuf and Delivy |  |  | P3ALL2N5 | P3ALL2N5 | 860 | ALL2 | 00 | 2DC8500 | 200 | 200 | 400 | P | LND | C2 | P | B | PB48 | LUZ2 | E | LND | DC |  |
| P3A02BF | A02B Polymer W.Basket - Bid tab Client appr. |  | 5d | 2010-08-16 A | 2010-08-20 A | E3A02B30 | 100% |  |  |  |  |  |  | P3A02BF | P3A02BF | 860 | A02B | 00 | 2DC9840 | 200 | 200 | 400 | P | PMT | 0 | P | B | PB12 | LUZ2 | E | PMT |  |  |
| P3A06AG | A06A Gost R Certificate to russ. customs | milestone | 0d | 2010-08-19 A | 2010-08-19 A | P3A06AN FF-90d | 100% |  |  |  | TB26 - 2 - Manuf and Delivy |  |  | P3A06AG | P3A06AG | 860 | A06A | 00 | 2DC9080 | 200 | 200 | 400 | P | LND | 0 | P | B | PB28 | LUZ2 | E | LND |  |  |
| P3A07M | A07 R Fines Eductor - Goods delivered FOB | milestone | 0d | 2010-08-20 A | 2010-08-20 A | P3A07L FF+10d | 100% |  |  |  | TB26 - 2 - Manuf and Delivy | 21,390 | 21,390 | P3A07M | P3A07M | 860 | A07 | 00 | 2DC8640 | 200 | 200 | 400 | P | LND | C2 | P | B | PB98 | LUZ2 | E | LND | DC |  |
| P3A03G | A03 Gost R Certificate to russ. customs | milestone | 0d | 2010-08-22 A | 2010-08-22 A | P3A03N FF-90d | 100% |  |  |  | TB26 - 2 - Manuf and Delivy |  |  | P3A03G | P3A03G | 860 | A03 | 00 | 2DC9630 | 200 | 200 | 400 | P | LND | 0 | P | B | PB98 | LUZ2 | E | LND |  |  |
| P3A13G | A13 Gost R Certificate to russ. customs | milestone | 0d | 2010-08-27 A | 2010-08-27 A | P3A13N FF-90d | 100% |  |  |  | TB26 - 2 - Manuf and Delivy |  |  | P3A13G | P3A13G | 860 | A13 | 00 | 2DC9060 | 200 | 200 | 400 | P | LND | 0 | P | B | PB98 | LUZ2 | E | LND |  |  |
| P3A02BD | A02B Polymer W.Basket - PO issued | milestone | 0d | 2010-08-31 A | 2010-08-31 A | P3A02BF FF, E3A02B30 FF, P3A02BC FF | 100% |  |  |  |  | 11,515 | 11,515 | P3A02BD | P3A02BD | 860 | A02B | 00 | 2DC9840 | 200 | 200 | 400 | P | LND | 0 | P | B | PB13 | LUZ2 | P | LND |  |  |
| P3A02BL | A02B Polymer W.Basket - Lead Time/Fabrication |  | 179d | 2010-09-01 A | 2011-03-01 A | P3A02BD | 100% |  |  |  | TB26 - 2 - Manuf and Delivy |  |  | P3A02BL | P3A02BL | 860 | A02B | 00 | 2DC9840 | 200 | 200 | 400 | P | LND | 0 | P | B | PB16 | LUZ2 | E | LND |  | DEL |
| P3A03X | A03 Catalyst Drum Roller - Final Inspection | milestone | 0d | 2010-09-02 A | 2010-09-02 A | E3A0350 FF, E3A0360 FF, P3A03L FF-15d | 100% |  |  |  | TB26 - 2 - Manuf and Delivy | 20,190 | 20,190 | P3A03X | P3A03X | 860 | A03 | 00 | 2DC9630 | 200 | 200 | 400 | P | LND | 0 | P | B | PB97 | LUZ2 | E | LND |  |  |
| P3A13X | A13 Scales - Final Inspection | milestone | 0d | 2010-09-15 A | 2010-09-15 A | P3A13L FF-16d, E3A1350 FF, E3A1360 FF | 100% |  |  |  | TB26 - 2 - Manuf and Delivy | 71,164.8 | 71,164.8 | P3A13X | P3A13X | 860 | A13 | 00 | 2DC9060 | 200 | 200 | 400 | P | LND | 0 | P | B | PB97 | LUZ2 | E | LND |  |  |
| P3A06AX | A06A Electrical Heater - Final Inspection | milestone | 0d | 2010-09-23 A | 2010-09-23 A | E3A06A50 FF, E3A06A60 FF, P3A06AL FF-10d | 100% |  |  |  | TB26 - 2 - Manuf and Delivy | 22,566 | 22,566 | P3A06AX | P3A06AX | 860 | A06A | 00 | 2DC9080 | 200 | 200 | 400 | P | LND | 0 | P | B | PB27 | LUZ2 | E | LND |  |  |
| P3A03M | A03 Catalyst Drum Roller - Goods deliv. FOB | milestone | 0d | 2010-09-30 A | 2010-09-30 A | P3A03X FF, P3A03L FF+10d | 100% |  |  |  | TB26 - 2 - Manuf and Delivy | 10,095 | 10,095 | P3A03M | P3A03M | 860 | A03 | 00 | 2DC9630 | 200 | 200 | 400 | P | LND | 0 | P | B | PB98 | LUZ2 | E | LND |  |  |
| P3A05N | A05 Offgas Cyclone&R - Transport to Site - depends on client (providing/clarification TSF Area) |  | 27d | 2010-10-04 A | 2010-10-30 A | P3A05L, P3A05X, P3A05M | 100% |  |  |  | TB26 - 2 - Manuf and Delivy |  |  | P3A05N | P3A05N | 860 | A05 | 00 | 2DC8590 | 200 | 200 | 400 | P | LND | C2 | P | B | PB18 | LUZ2 | E | LND | DC |  |
| P3A11G | A11 Gost R Certificate to russ. customs | milestone | 0d | 2010-10-07 A | 2010-10-07 A | P3A11N FF-90d | 100% |  |  |  | TB26 - 2 - Manuf and Delivy |  |  | P3A11G | P3A11G | 860 | A11 | 00 | 2KB4420 | 200 | 200 | 400 | P | LND | 0 | P | B | PB98 | LUZ2 | E | LND |  |  |
| P3A04AX | A04A R Overhead Cond. - Final Inspection |  | 3d | 2010-10-11 A | 2010-10-13 A | P3A04AL FF-25d, E3A04A60 FF+10d | 100% |  |  |  | TB26 - 2 - Manuf and Delivy | 593,100 | 593,100 | P3A04AX | P3A04AX | 860 | A04A | 00 | 2DC9110 | 200 | 200 | 400 | P | LND | C2 | P | B | PB17 | LUZ2 | E | LND | DC |  |
| P3A04AG | A04A Gost R Certificate to russ. customs | milestone | 0d | 2010-10-15 A | 2010-10-15 A | P3A04AN FF-90d | 100% |  |  |  | TB26 - 2 - Manuf and Delivy |  |  | P3A04AG | P3A04AG | 860 | A04A | 00 | 2DC9110 | 200 | 200 | 400 | P | LND | 0 | P | B | PB18 | LUZ2 | E | LND |  |  |

Notes:
- P3ALL4X: Expenses: 900A 1161870
- HPB20: UDF_Actictity Name (Russia): Статическое оборудование - Оставшиеся заказы на проектирование
- P3A03D: Expenses: 900A 13460
- HPBA03: UDF_Actictity Name (Russia): Рольганг емкости с катализатором (A03), заказ на поставку/изготовление/транспортировка на площадку
- P3A01D: Expenses: 900A 82032
- P3A02CD: Expenses: 900A 24800
- P3A06D: Expenses: 900A 37280
- P3A17D: Expenses: 900A 0
- HPBA01: UDF_Actictity Name (Russia): Напорное оборудование (A01), заказ на поставку/изготовление/транспортировка на площадку
- HPBA02B: UDF_Actictity Name (Russia): Корзиночный фильтр воды (A02B), заказ на поставку/изготовление/транспортировка на площадку
- HPBA06: UDF_Actictity Name (Russia): Предпусковой подогреватель (A06), заказ на поставку/изготовление/транспортировка на площадку
- HPBA17: UDF_Actictity Name (Russia): Внутренние детали колонн (A17), заказ на поставку/изготовление/транспортировка на площадку
- P3ALL4M1: Expenses: 900A 580935
- P3A06AD: Expenses: 900A 15044
- HPBA06A: UDF_Actictity Name (Russia): Подогреватель азота (A06A), заказ на поставку/изготовление/транспортировка на площадку
- P3A13D: Expenses: 900A 47443
- HPBA13: UDF_Actictity Name (Russia): Весы (A13), заказ на поставку/изготовление/транспортировка на площадку
- P3A04M: Expenses: 900A 96553.8
- P3ALL2M: Expenses: 900A 198258
- P3A04N: P3 Activity Log Info: over Black Sea Port(35), / Truck(20), Cust.cl (30)
- P3A04N1: P3 Activity Log Info: Shipmet Korea - / Antwerpen
- P3ALL2N: P3 Activity Log Info: Ship / Antwerpen(40),Archangelsk(30),Tobolsk (25)
- P3ALL2N1: P3 Activity Log Info: Shipment Korea - / Antwerpen
- P3ALL4N1: P3 Activity Log Info: per / Truck/Rail
- P3A04N2: P3 Activity Log Info: North / Sea
- P3ALL2N2: P3 Activity Log Info: North / Sea
- P3ALL4N2: P3 Activity Log Info: per / Truck/Rail
- P3A05X: Expenses: 900A 107473
- P3ALL4N3: P3 Activity Log Info: per / Truck/Rail
- P3A05M: Expenses: 900A 53736.6
- P3A04N3: P3 Activity Log Info: River / (Irtysch/Tobol)
- P3ALL2N3: P3 Activity Log Info: River / (Irtysch/Tobol)
- P3A02AD: Expenses: 900A 90920
- HPBA02A: UDF_Actictity Name (Russia): Сепаратор факела (A02A), заказ на поставку/изготовление/транспортировка на площадку
- P3A07M: P3 Activity Log Info: will be storaged by / packer / Expenses: 900A 21390
- P3A02BD: Expenses: 900A 11515
- P3A03X: Expenses: 900A 20190
- P3A13X: Expenses: 900A 71164.8
- P3A06AX: Expenses: 900A 22566
- P3A03M: Expenses: 900A 10095
- P3A05N: P3 Activity Log Info: Rail/Truck (30days), / custom clearance (30days)
- P3A04AX: Expenses: 900A 593100

| ID | Activity | Type | Duration | Start | Finish | Predecessors | Complete | Remaining | Planned start | Planned finish | Total float | Free float | Constraint | Expected finish | Calendar | Cost | Actual cost | UDF_SAVE ACTID | UDF_SAVE ACT ID | Department | Type of Work | Constr. Area | Inquiry/Order No | PMT-Area | PMT-Schedule Org | PMT-Discipline | PMT-Phase | PMT-Respons. | Zeigen/n. Zeigen | WBS Phase | WBS Discipline | WBS Type of Work | WBS Objects | IMS | UPT | Pro Unit/DocCode | PMT-Doc. Type |
| --- | --- | --- | --- | --- | --- | --- | --- | --- | --- | --- | --- | --- | --- | --- | --- | --- | --- | --- | --- | --- | --- | --- | --- | --- | --- | --- | --- | --- | --- | --- | --- | --- | --- | --- | --- | --- | --- |
| P3A06AM | A06A Electrical Heater - Goods deliv. FOB/FCA | milestone | 0d | 2010-10-15 A | 2010-10-15 A | P3A06AL FF+15d, P3A06AX FF, P3A06AD | 100% |  |  |  |  |  |  |  | TB26 - 2 - Manuf and Delivy | 11,283 | 11,283 | P3A06AM | P3A06AM | 860 | A06A | 00 | 2DC9080 | 200 | 200 | 400 | P | LND | 0 | P | B | PB28 | LUZ2 | E | LND |  |  |
| P3A08G | A08 Gost R Certificate to russ. customs | milestone | 0d | 2010-10-28 A | 2010-10-28 A | P3A08N FF-90d | 100% |  |  |  |  |  |  |  | TB26 - 2 - Manuf and Delivy |  |  | P3A08G | P3A08G | 860 | A08 | 00 | 2DC8560 | 200 | 200 | 400 | P | LND | 0 | P | B | PB88 | LUZ2 | E | LND |  |  |
| P3A16G | A16 Gost R Certificate to russ. customs | milestone | 0d | 2010-10-28 A | 2010-10-28 A | P3A16N FF-90d | 100% |  |  |  |  |  |  |  | TB26 - 2 - Manuf and Delivy |  |  | P3A16G | P3A16G | 860 | A16 | 00 | 2DC8560 | 200 | 200 | 400 | P | LND | 0 | P | B | PB88 | LUZ2 | E | LND |  |  |
| P3A03N | A03 Catalyst Drum Roller - Transport to Site, depends on availability of TSF area |  | 66d | 2010-10-29 A | 2011-01-05 A | P3A03M | 100% |  |  |  |  |  |  |  | TB26 - 2 - Manuf and Delivy |  |  | P3A03N | P3A03N | 860 | A03 | 00 | 2DC9630 | 200 | 200 | 400 | P | LND | 0 | P | B | PB98 | LUZ2 | E | LND |  |  |
| P3A07N | A07 R Fines Eductor - Transport to Site - depends on client (providing/clarification TSF Area) |  | 66d | 2010-10-29 A | 2011-01-05 A | P3A07L, P3A07X, P3A07M | 100% |  |  |  |  |  |  |  | TB26 - 2 - Manuf and Delivy |  |  | P3A07N | P3A07N | 860 | A07 | 00 | 2DC8640 | 200 | 200 | 400 | P | LND | C2 | P | B | PB98 | LUZ2 | E | LND | DC |  |
| P3A13M | A13 Scales - Goods deliv. FOB | milestone | 0d | 2010-10-29 A | 2010-10-29 A | P3A13X FF, P3A13L FF+20d | 100% |  |  |  |  |  |  |  | TB26 - 2 - Manuf and Delivy | 35,582.4 | 35,582.4 | P3A13M | P3A13M | 860 | A13 | 00 | 2DC9060 | 200 | 200 | 400 | P | LND | 0 | P | B | PB98 | LUZ2 | E | LND |  |  |
| P3A13N | A13 Scales - Transport to Site, depends on availability of TSF area's |  | 26d | 2010-11-05 A | 2010-11-30 A | P3A13M | 100% |  |  |  |  |  |  |  | TB26 - 2 - Manuf and Delivy |  |  | P3A13N | P3A13N | 860 | A13 | 00 | 2DC9060 | 200 | 200 | 400 | P | LND | 0 | P | B | PB98 | LUZ2 | E | LND |  |  |
| P3A11X | A11 Unloading Arms - Final Inspection | milestone | 0d | 2010-11-11 A | 2010-11-11 A | E3A1160 FF, P3A11L FF-3d, E3A1150 FF | 100% |  |  |  |  |  |  |  | TB26 - 2 - Manuf and Delivy | 43,212 | 43,212 | P3A11X | P3A11X | 860 | A11 | 00 | 2KB4420 | 200 | 200 | 400 | P | LND | 0 | P | B | PB97 | LUZ2 | E | LND |  |  |
| P3A04AM | A04A R Overhead Cond. - Goods delivered FOB | milestone | 0d | 2010-11-15 A | 2010-11-15 A | P3A04AL FF+10d | 100% |  |  |  |  |  |  |  | TB26 - 2 - Manuf and Delivy | 296,550 | 296,550 | P3A04AM | P3A04AM | 860 | A04A | 00 | 2DC9110 | 200 | 200 | 400 | P | LND | C2 | P | B | PB18 | LUZ2 | E | LND | DC |  |
| P3A04AN | A04A R Overhead Cond. - Transport to Site |  | 35d | 2010-11-16 A | 2010-12-20 A | P3A04AL, P3A04AM, P3A04AX | 100% |  |  |  |  |  |  |  | TB26 - 2 - Manuf and Delivy |  |  | P3A04AN | P3A04AN | 860 | A04A | 00 | 2DC9110 | 200 | 200 | 400 | P | LND | C2 | P | B | PB18 | LUZ2 | E | LND | DC |  |
| P3A11M | A11 Unloading Arms - Goods deliv. FOB | milestone | 0d | 2010-11-25 A | 2010-11-25 A | P3A11L FF+10d, P3A11D, P3A11X FF | 100% |  |  |  |  |  |  |  | TB26 - 2 - Manuf and Delivy | 21,606 | 21,606 | P3A11M | P3A11M | 860 | A11 | 00 | 2KB4420 | 200 | 200 | 400 | P | LND | 0 | P | B | PB98 | LUZ2 | E | LND |  |  |
| P3A01G | A01 Gost R Certificate to russ. customs | milestone | 0d | 2010-12-01 A | 2010-12-01 A | P3A01N FF-90d | 100% |  |  |  |  |  |  |  | TB26 - 2 - Manuf and Delivy |  |  | P3A01G | P3A01G | 860 | A01 | 00 | 2DD8530 | 200 | 200 | 400 | P | LND | 0 | P | B | PB18 | LUZ2 | E | LND |  |  |
| P3A16X | A16 Offgas C Filters - Final Inspection |  | 5d | 2010-12-06 A | 2010-12-10 A | E3A1660 FF+10d, P3A16L FF-7d, P3A16D2 | 100% |  |  |  |  |  |  |  | TB26 - 2 - Manuf and Delivy | 114,600 | 114,600 | P3A16X | P3A16X | 860 | A16 | 00 | 2DC8560 | 200 | 200 | 400 | P | LND | C2 | P | B | PB87 | LUZ2 | E | LND | DC |  |
| P3A08X | A08 Vent/Bag Filter - Final Inspection |  | 2d | 2010-12-08 A | 2010-12-09 A | E3A0860 FF+10d, P3A08D2, P3A08L FF-8d | 100% |  |  |  |  |  |  |  | TB26 - 2 - Manuf and Delivy | 364,200 | 364,200 | P3A08X | P3A08X | 860 | A08 | 00 | 2DC8560 | 200 | 200 | 400 | P | LND | C2 | P | B | PB87 | LUZ2 | E | LND | DC |  |
| P3A00D | A00 Mechanical Subcontract - Contract award delayed by client !! VNZM (Prefab Hall's not useable yet !!) | milestone | 0d | 2010-12-10 A | 2010-12-10 A | A1010240 FF | 100% |  |  |  |  |  |  |  |  |  |  | P3A00D | P3A00D | 860 | A00 | 00 | 2MD6880 | 200 | 200 | 400 | P | LND | 0 | P | B | PM11 | LUZ2 | SS | LND |  | DEV |
| P3A01X | A01 Drums/Small Vessels - Final Inspection | milestone | 0d | 2011-01-07 A | 2011-01-07 A | P3A01L FF-30d, E3A0150 FF, E3A0160 FF | 100% |  |  |  |  |  |  |  | TB26 - 2 - Manuf and Delivy | 123,048 | 123,048 | P3A01X | P3A01X | 860 | A01 | 00 | 2DD8530 | 200 | 200 | 400 | P | LND | 0 | P | B | PB17 | LUZ2 | E | LND |  |  |
| P3A02CX | A02C Instrument Air Vessels - Final Inspection | milestone | 0d | 2011-01-07 A | 2011-01-07 A | P3A02CL FF-30d, E3A02C50 FF, E3A02C60 | 100% |  |  |  |  |  |  |  | TB26 - 2 - Manuf and Delivy | 37,200 | 37,200 | P3A02CX | P3A02CX | 860 | A02C | 00 | 2DD8530 | 200 | 200 | 400 | P | LND | 0 | P | B | PB17 | LUZ2 | E | LND |  |  |
| P3A06X | A06 Start-Up Heater/Condenser - Final Inspection | milestone | 0d | 2011-01-07 A | 2011-01-07 A | E3A0650 FF, E3A0660 FF, P3A06L FF-30d | 100% |  |  |  |  |  |  |  | TB26 - 2 - Manuf and Delivy | 55,920 | 55,920 | P3A06X | P3A06X | 860 | A06 | 00 | 2DD8530 | 200 | 200 | 400 | P | LND | 0 | P | B | PB27 | LUZ2 | E | LND |  |  |
| P3A02CG | A02C Gost R Certificate to russ. customs | milestone | 0d | 2011-01-12 A | 2011-01-12 A | P3A02CN FF-90d | 100% |  |  |  |  |  |  |  | TB26 - 2 - Manuf and Delivy |  |  | P3A02CG | P3A02CG | 860 | A02C | 00 | 2DD8530 | 200 | 200 | 400 | P | LND | 0 | P | B | PB18 | LUZ2 | E | LND |  |  |
| P3A06G | A06 Gost R Certificate to russ. customs | milestone | 0d | 2011-01-12 A | 2011-01-12 A | P3A06N FF-90d | 100% |  |  |  |  |  |  |  | TB26 - 2 - Manuf and Delivy |  |  | P3A06G | P3A06G | 860 | A06 | 00 | 2DD8530 | 200 | 200 | 400 | P | LND | 0 | P | B | PB28 | LUZ2 | E | LND |  |  |
| P3A02BG | A02B Gost R Certificate to russ. customs | milestone | 0d | 2011-01-16 A | 2011-01-16 A | P3A02BN FF-90d | 100% |  |  |  |  |  |  |  | TB26 - 2 - Manuf and Delivy |  |  | P3A02BG | P3A02BG | 860 | A02B | 00 | 2DC9840 | 200 | 200 | 400 | P | LND | 0 | P | B | PB18 | LUZ2 | E | LND |  |  |
| P3A17X | A17 Teal S. C. Internal - Final Inspection | milestone | 0d | 2011-01-17 A | 2011-01-17 A | E3A1750 FF, P3A17L FF-20d, E3A1760 FF | 100% |  |  |  |  |  |  |  | TB26 - 2 - Manuf and Delivy |  |  | P3A17X | P3A17X | 860 | A17 | 00 | 2DD8530 | 200 | 200 | 400 | P | LND | 0 | P | B | PB17 | LUZ2 | E | LND |  |  |
| P3A08M | A08 Vent/Bag Filter - Goods delivered FCA/FOB | milestone | 0d | 2011-01-31 A | 2011-01-31 A | P3A08L FF+5d | 100% |  |  |  |  |  |  |  | TB26 - 2 - Manuf and Delivy | 182,100 | 182,100 | P3A08M | P3A08M | 860 | A08 | 00 | 2DC8560 | 200 | 200 | 400 | P | LND | C2 | P | B | PB88 | LUZ2 | E | LND | DC |  |
| P3A16M | A16 Offgas C Filters- Goods delivered FOB | milestone | 0d | 2011-01-31 A | 2011-01-31 A | P3A16L FF+5d | 100% |  |  |  |  |  |  |  | TB26 - 2 - Manuf and Delivy | 57,300 | 57,300 | P3A16M | P3A16M | 860 | A16 | 00 | 2DC8560 | 200 | 200 | 400 | P | LND | C2 | P | B | PB88 | LUZ2 | E | LND | DC |  |
| P3A00S3 | A00 Mechanical Subcontract - Start Prefabrication Piping (Start Cooling Water Line) | milestone | 0d | 2011-02-01 A | 2011-02-01 A | P3A00D FS+10d | 100% |  |  |  |  |  |  |  |  |  |  | P3A00S3 | P3A00S3 | 860 | A00 | 00 | 2MD6880 | 200 | 200 | 400 | P | CC | 0 | P | B | PM11 | LUZ2 | SS | LND |  | DEV |
| P3A02AX | A02A Large Drums - Final Inspection 1st LOT | milestone | 0d | 2011-02-11 A | 2011-02-11 A | P3A02AL FF-43d, A1KL1130F FF, E3A02A50 FF, E3A02A60 | 100% |  |  |  |  |  |  |  | TB26 - 2 - Manuf and Delivy | 136,380 | 136,380 | P3A02AX | P3A02AX | 860 | A02A | 00 | 2DC9450 | 200 | 200 | 400 | P | LND | 0 | P | B | PB17 | LUZ2 | E | LND |  |  |
| P3A08N | A08 Vent/Bag Filter - Transport to Site |  | 45d | 2011-02-14 A | 2011-03-30 A | P3A08X, P3A08L, P3A08M FS+13d | 100% |  |  |  |  |  |  |  | TB26 - 2 - Manuf and Delivy |  |  | P3A08N | P3A08N | 860 | A08 | 00 | 2DC8560 | 200 | 200 | 400 | P | LND | C2 | P | B | PB88 | LUZ2 | E | LND | DC |  |
| P3A16N | A16 Offgas C Filters - Transport to Site |  | 45d | 2011-02-14 A | 2011-03-30 A | P3A16L, P3A16X, P3A16M FS+13d | 100% |  |  |  |  |  |  |  | TB26 - 2 - Manuf and Delivy |  |  | P3A16N | P3A16N | 860 | A16 | 00 | 2DC8560 | 200 | 200 | 400 | P | LND | C2 | P | B | PB88 | LUZ2 | E | LND | DC |  |
| P3A02BX | A02B Polymer W.Basket - Final Inspection | milestone | 0d | 2011-02-24 A | 2011-02-24 A | E3A02B60, P3A02BL FF-6d, E3A02B50 FF | 100% |  |  |  |  |  |  |  | TB26 - 2 - Manuf and Delivy | 17,272.5 | 17,272.5 | P3A02BX | P3A02BX | 860 | A02B | 00 | 2DC9840 | 200 | 200 | 400 | P | LND | 0 | P | B | PB17 | LUZ2 | E | LND |  |  |
| P3A02BM | A02B Polymer W.Basket - Goods deliv. FOB/FCA | milestone | 0d | 2011-03-11 A | 2011-03-11 A | P3A02BL FF+10d, P3A02BX FF | 100% |  |  |  |  |  |  |  | TB26 - 2 - Manuf and Delivy | 8,636.25 | 8,636.25 | P3A02BM | P3A02BM | 860 | A02B | 00 | 2DC9840 | 200 | 200 | 400 | P | LND | 0 | P | B | PB18 | LUZ2 | E | LND |  |  |
| P3A01M | A01 Drums/Small Vessels - Goods delivered FCA | milestone | 0d | 2011-03-15 A | 2011-03-15 A | P3A01L FF+15d, P3A01X FF | 100% |  |  |  |  |  |  |  | TB26 - 2 - Manuf and Delivy | 61,524 | 61,524 | P3A01M | P3A01M | 860 | A01 | 00 | 2DD8530 | 200 | 200 | 400 | P | LND | 0 | P | B | PB18 | LUZ2 | E | LND |  |  |
| P3A02CM | A02C Instrument Air Vessels - Goods deliv. FCA | milestone | 0d | 2011-03-15 A | 2011-03-15 A | P3A02CL FF+15d, P3A02CX FF | 100% |  |  |  |  |  |  |  | TB26 - 2 - Manuf and Delivy | 18,600 | 18,600 | P3A02CM | P3A02CM | 860 | A02C | 00 | 2DD8530 | 200 | 200 | 400 | P | LND | 0 | P | B | PB18 | LUZ2 | E | LND |  |  |
| P3A06M | A06 Start-Up Heater/Condenser - Goods deliv. FCA | milestone | 0d | 2011-03-15 A | 2011-03-15 A | P3A06X FF, P3A06L FF+15d | 100% |  |  |  |  |  |  |  | TB26 - 2 - Manuf and Delivy | 27,960 | 27,960 | P3A06M | P3A06M | 860 | A06 | 00 | 2DD8530 | 200 | 200 | 400 | P | LND | 0 | P | B | PB28 | LUZ2 | E | LND |  |  |
| P3A17M | A17 Teal S. C. Internal - Goods delivered FCA | milestone | 0d | 2011-03-15 A | 2011-03-15 A | P3A17X FF, P3A17L FF+15d | 100% |  |  |  |  |  |  |  | TB26 - 2 - Manuf and Delivy |  |  | P3A17M | P3A17M | 860 | A17 | 00 | 2DD8530 | 200 | 200 | 400 | P | LND | 0 | P | B | PB18 | LUZ2 | E | LND |  |  |
| P3A02AM | A02A Large Drums - Goods deliv. FOB | milestone | 0d | 2011-04-08 A | 2011-04-08 A | P3A02AX FF, P3A02AL FF+8d | 100% |  |  |  |  |  |  |  | TB26 - 2 - Manuf and Delivy | 68,190 | 68,190 | P3A02AM | P3A02AM | 860 | A02A | 00 | 2DC9450 | 200 | 200 | 400 | P | LND | 0 | P | B | PB18 | LUZ2 | E | LND |  |  |
| P3A02AN | A02A Large Drums - Transport to Site remaining |  | 5d | 2011-04-09 A | 2011-04-13 A | P3A02AM | 100% |  |  |  |  |  |  |  | TB26 - 2 - Manuf and Delivy |  |  | P3A02AN | P3A02AN | 860 | A02A | 00 | 2DC9450 | 200 | 200 | 400 | P | LND | 0 | P | B | PB18 | LUZ2 | E | LND |  |  |
| P3A00S2 | A00 Mechanical Subcontract - Start Install HVAC CA16 | milestone | 0d | 2011-04-23 A | 2011-04-23 A | P3H01D | 100% |  | 2011-04-25 | 2011-04-25 |  |  |  |  |  |  |  | P3A00S2 | P3A00S2 | 860 | H01 | 00 | H01 | 200 | 200 | 400 | P | CC | 0 | P | B | PM11 | LUZ2 | SS | LND |  | DEV |
| P3A12D | A12 Overhead Cranes - PO issued >32t | milestone | 0d | 2011-05-06 A | 2011-05-06 A | P3A12C, F2940 FF, E3A1205, E3A1230 FF-10d | 100% |  |  |  |  |  |  |  |  |  |  | P3A12D | P3A12D | 860 | A12 | 00 | 2KB4740 | 200 | 200 | 400 | P | LND | 0 | P | B | PB93 | LUZ2 | P | LND |  |  |
| P3A12D1 | A12 Overhead Cranes - PO issued <32t | milestone | 0d | 2011-05-06 A | 2011-05-06 A | F2940 FF, E3A1230, P3A12C, E3A1205 | 100% |  |  |  |  |  |  |  |  |  |  | P3A12D | P3A12D1 | 860 | A12 | 00 | 2KB4740 | 200 | 200 | 400 | P | LND | 0 | P | B | PB93 | LUZ2 | P | LND |  |  |
| HPBA12 | Cranes (A12) PO/Fabr./Transport to Site | level of effort | 100d | 2011-05-07 A | 2011-09-23 | P3A12L SS |  | 17d | 2011-05-09 | 2011-09-23 | 379d | 0d |  |  |  |  |  | HPBA12 | HPBA12 | 869 |  | 00 |  | 200 | 200 | 400 | E | LND | L2 | P | B | PB93 | LUZ2 | E | LND |  | DFA |
| P3A12L | A12 Overhead Cranes - Lead Time/Fabrication |  | 117d | 2011-05-07 A | 2011-08-31 A | P3A12D, P3A12D1 | 100% |  |  |  |  |  |  |  | TB26 - 2 - Manuf and Delivy |  |  | P3A12L | P3A12L | 860 | A12 | 00 | 2KB4740 | 200 | 200 | 400 | P | LND | 0 | P | B | PB96 | LUZ2 | E | LND |  | DEL |
| P3A02DA | A02D Vessels Chiller Unit - Prepare/Issue RFQ |  | 3d | 2011-05-10 A | 2011-05-12 A | E3A02D10 | 100% |  |  |  |  |  |  |  |  |  |  | P3A02AA | P3A02DA | 860 | A02D | 00 | A02D | 200 | 200 | 400 | P | LND |  | P | B | PB11 | LUZ2 | E | LND |  | DEV |
| P3M18A | M18 Pumps Chiller Unit - Prepare/Issue RFQ |  | 3d | 2011-05-10 A | 2011-05-12 A | E3M1810 | 100% |  |  |  |  |  |  |  |  |  |  | P3A02AA | P3M18A | 860 | M18 | 00 | 2PA6720 | 200 | 200 | 400 | P | LND |  | P | M | PB11 | LUZ2 | E | LND |  | DEV |
| P3A02DB | A02D Vessels Chiller Unit - RFQ issued | milestone | 0d | 2011-05-12 A | 2011-05-12 A | P3A02DA FF | 100% |  |  |  |  |  |  |  |  |  |  | P3A02AB | P3A02DB | 860 | A02D | 00 | A02D | 200 | 200 | 400 | P | LND |  | P | B | PB11 | LUZ2 | E | LND |  | DEV |
| P3M18B | M18 Pumps Chiller Unit - RFQ issued | milestone | 0d | 2011-05-12 A | 2011-05-12 A | P3M18A FF | 100% |  |  |  |  |  |  |  |  |  |  | P3A02AB | P3M18B | 860 | M18 | 00 | 2PA6720 | 200 | 200 | 400 | P | LND |  | P | M | PB11 | LUZ2 | E | LND |  | DEV |
| P3A06AN | A06A Electrical Heater - Transport to Site (collection of div. packages) |  | 23d | 2011-05-19 A | 2011-06-10 A | P3A06AM | 100% |  |  |  |  |  |  |  | TB26 - 2 - Manuf and Delivy |  |  | P3A06AN | P3A06AN | 860 | A06A | 00 | 2DC9080 | 200 | 200 | 400 | P | LND | 0 | P | B | PB28 | LUZ2 | E | LND |  |  |
| P3A02DC | A02D Vessels Chiller Unit - Eval./Negotiation |  | 50d | 2011-06-03 A | 2011-08-11 A | P3A02DB, E3A02D20 FF | 100% |  |  |  |  |  |  |  |  |  |  | P3A02AC | P3A02DC | 860 | A02D | 00 | A02D | 200 | 200 | 400 | P | LND |  | P | B | PB12 | LUZ2 | E | LND |  |  |
| P3M18C | M18 Pumps Chiller Unit - Eval./Negotiation |  | 35d | 2011-06-10 A | 2011-07-28 A | E3M1820 FF, P3M18B | 100% |  |  |  |  |  |  |  |  |  |  | P3A02AC | P3M18C | 860 | M18 | 00 | 2PA6720 | 200 | 200 | 400 | P | LND |  | P | M | PB12 | LUZ2 | E | LND |  |  |
| P3A01N | A01 Drums/Small Vessels - Transport to Site (Mumbai - Tobolsk) |  | 103d | 2011-06-28 A | 2011-10-08 | P3A01M FS+62d, P3A01X |  | 38d |  |  | -53d | 0d |  |  | TB26 - 2 - Manuf and Delivy |  |  | P3A01N | P3A01N | 860 | A01 | 00 | 2DD8530 | 200 | 200 | 400 | P | LND | 0 | P | B | PB18 | LUZ2 | E | LND |  |  |
| P3A01N1 | A01 Drums/Small Vessels - Shipm. Mumbai (India) - Xingang (China) on hold custom clarifications |  | 73d | 2011-06-28 A | 2011-09-08 | P3A01N SS |  | 8d |  |  | 5d | 0d |  |  | TB26 - 2 - Manuf and Delivy |  |  | P3A02CN1 | P3A01N1 | 860 | A01 | 00 | 2DD8530 | 200 | 200 | 400 | P | LND | C2 | P | B | PB48 | LUZ2 | E | LND | DC |  |
| P3A02CN | A02C Instrument Air Vessels - Transport to Site (Mumbai - Tobolsk) |  | 103d | 2011-06-28 A | 2011-10-08 | P3A02CM FS+62d |  | 38d |  |  | -82d | 0d |  |  | TB26 - 2 - Manuf and Delivy |  |  | P3A02CN | P3A02CN | 860 | A02C | 00 | 2DD8530 | 200 | 200 | 400 | P | LND | 0 | P | B | PB18 | LUZ2 | E | LND |  |  |
| P3A02CN1 | A02C Instrument Air Vessels - Shipm. Mumbai (India) - Xingang (China) on hold custom clarifications |  | 73d | 2011-06-28 A | 2011-09-08 | P3A02CN SS |  | 8d |  |  | -82d | 0d |  |  | TB26 - 2 - Manuf and Delivy |  |  | P3A02CN1 | P3A02CN1 | 860 | A02C | 00 | 2DD8530 | 200 | 200 | 400 | P | LND | C2 | P | B | PB48 | LUZ2 | E | LND | DC |  |
| P3A02DF | A02D Vessels Chiller Unit - Bid tab Client appr. |  | 31d | 2011-06-28 A | 2011-08-09 A | E3A02D30 | 100% |  |  |  |  |  |  |  |  |  |  | P3A02AF | P3A02DF | 860 | A02D | 00 | A02D | 200 | 200 | 400 | P | PMT |  | P | B | PB12 | LUZ2 | E | PMT |  |  |
| P3A06N | A06 Start-Up Heater/Condenser - Transport to Site (Mumbai - Tobolsk) |  | 103d | 2011-06-28 A | 2011-10-08 | P3A06M FS+62d |  | 38d |  |  | -86d | 0d | start on 2011-06-28 |  | TB26 - 2 - Manuf and Delivy |  |  | P3A06N | P3A06N | 860 | A06 | 00 | 2DD8530 | 200 | 200 | 400 | P | LND | 0 | P | B | PB28 | LUZ2 | E | LND |  |  |
| P3A06N1 | A06 Start-Up Heater/Condenser - Shipm. Mumbai (India) - Xingang (China) on hold custom clarifications |  | 73d | 2011-06-28 A | 2011-09-08 | P3A06N SS |  | 8d |  |  | -86d | 0d |  |  | TB26 - 2 - Manuf and Delivy |  |  | P3A06N1 | P3A06N1 | 860 | A06 | 00 | 2DD8530 | 200 | 200 | 400 | P | LND | C2 | P | B | PB48 | LUZ2 | E | LND | DC |  |
| P3A17N | A17 Teal S. C. Internal - Transport to Site (Mumbai - Tobolsk) |  | 103d | 2011-06-28 A | 2011-10-08 | P3A17M FS+62d |  | 38d |  |  | 603.5d | 0d |  |  | TB26 - 2 - Manuf and Delivy |  |  | P3A17N | P3A17N | 860 | A17 | 00 | 2DD8530 | 200 | 200 | 400 | P | LND | 0 | P | B | PB18 | LUZ2 | E | LND |  |  |
| P3A17N1 | A17 Teal S. C. Internal - Shipm. Mumbai (India) - Xingang (China) on hold custom clarifications |  | 73d | 2011-06-28 A | 2011-09-08 | P3A17N SS |  | 8d |  |  | 603.5d | 0d |  |  | TB26 - 2 - Manuf and Delivy |  |  | P3A17N1 | P3A17N1 | 860 | A17 | 00 | 2DD8530 | 200 | 200 | 400 | P | LND | C2 | P | B | PB48 | LUZ2 | E | LND | DC |  |
| P3M18F | M18 Pumps Chiller Unit - Bid tab Client appr. |  | 10d | 2011-07-19 A | 2011-08-01 A | E3M1830 | 100% |  |  |  |  |  |  |  |  |  |  | P3A02AF | P3M18F | 860 | M18 | 00 | 2PA6720 | 200 | 200 | 400 | P | PMT |  | P | M | PB12 | LUZ2 | E | PMT |  |  |
| P3M18D | M18 Pumps Chiller Unit - PO issued | milestone | 0d | 2011-08-01 A | 2011-08-01 A | P3M18F FF, E3M1830 FF, P3M18C FF | 100% |  |  |  |  |  |  |  |  |  |  | P3A02AD | P3M18D | 860 | M18 | 00 | 2PA6720 | 200 | 200 | 400 | P | LND |  | P | M | PB13 | LUZ2 | P | LND |  |  |
| P3M18L | M18 Pumps Chiller Unit - Lead Time/Fabrication |  | 176d | 2011-08-02 A | 2012-01-27 | P3M18D |  | 146d |  |  | 465.5d | 0d |  | 2012-01-27 | TB26 - 2 - Manuf and Delivy |  |  | P3A02AL | P3M18L | 860 | M18 | 00 | 2PA6720 | 200 | 200 | 400 | P | LND |  | P | M | PB16 | LUZ2 | E | LND |  | DEL |
| P3A02DD | A02D Vessels Chiller Unit - PO issued | milestone | 0d | 2011-08-11 A | 2011-08-11 A | P3A02DF FF, P3A02DC FF, E3A02D30 FF | 100% |  |  |  |  |  |  |  |  |  |  | P3A02AD | P3A02DD | 860 | A02D | 00 | A02D | 200 | 200 | 400 | P | LND |  | P | B | PB13 | LUZ2 | P | LND |  |  |
| P3A02DL | A02D Vessels Chiller Unit - Lead Time/Fabrication |  | 140d | 2011-08-12 A | 2011-12-31 | P3A02DD |  | 120d |  |  | 486.5d | 0d |  | 2011-12-31 | TB26 - 2 - Manuf and Delivy |  |  | P3A02AL | P3A02DL | 860 | A02D | 00 | A02D | 200 | 200 | 400 | P | LND |  | P | B | PB16 | LUZ2 | E | LND |  | DEL |
| P3A02BN | A02B Polymer W.Basket - Transport to Site (collection of div. packages) |  | 25d | 2011-08-26 A | 2011-09-19 | P3A02BM FS+166d |  | 19d |  |  | 63d | 0d |  |  | TB26 - 2 - Manuf and Delivy |  |  | P3A02BN | P3A02BN | 860 | A02B | 00 | 2DC9840 | 200 | 200 | 400 | P | LND | 0 | P | B | PB18 | LUZ2 | E | LND |  |  |
| P3A01N2 | A01 Drums/Small Vessels - Train Transport (Xingang -Tobolsk) |  | 25d | 2011-09-09 | 2011-10-03 | P3A01N1 |  |  |  |  | 5d | 0d |  |  | TB26 - 2 - Manuf and Delivy |  |  | P3A02CN2 | P3A01N2 | 860 | A01 | 00 | 2DD8530 | 200 | 200 | 400 | P | LND | C2 | P | B | PB48 | LUZ2 | E | LND | DC |  |
| P3A02CN2 | A02C Instrument Air Vessels - Train Transport (Xingang -Tobolsk) |  | 25d | 2011-09-09 | 2011-10-03 | P3A02CN1 |  |  |  |  | -82d | 0d |  |  | TB26 - 2 - Manuf and Delivy |  |  | P3A02CN2 | P3A02CN2 | 860 | A02C | 00 | 2DD8530 | 200 | 200 | 400 | P | LND | C2 | P | B | PB48 | LUZ2 | E | LND | DC |  |
| P3A06N2 | A06 Start-Up Heater/Condenser - Train Transport (Xingang -Tobolsk) |  | 25d | 2011-09-09 | 2011-10-03 | P3A06N1 |  |  |  |  | -86d | 0d |  |  | TB26 - 2 - Manuf and Delivy |  |  | P3A06N2 | P3A06N2 | 860 | A06 | 00 | 2DD8530 | 200 | 200 | 400 | P | LND | C2 | P | B | PB48 | LUZ2 | E | LND | DC |  |
| P3A17N2 | A17 Teal S. C. Internal - Train Transport (Xingang - Tobolsk) |  | 25d | 2011-09-09 | 2011-10-03 | P3A17N1 |  |  |  |  | 603.5d | 0d |  |  | TB26 - 2 - Manuf and Delivy |  |  | P3A17N2 | P3A17N2 | 860 | A17 | 00 | 2DD8530 | 200 | 200 | 400 | P | LND | C2 | P | B | PB48 | LUZ2 | E | LND | DC |  |
| P3A12M | A12 Overhead Cranes - Goods deliv. FOB | milestone | 0d | 2011-09-10 | 2011-09-10 | P3A12L FF+10d |  |  |  |  | -40d | 0d |  |  | TB26 - 2 - Manuf and Delivy |  |  | P3A12M | P3A12M | 860 | A12 | 00 | 2KB4740 | 200 | 200 | 400 | P | LND | 0 | P | B | PB98 | LUZ2 | E | LND |  |  |
| P3A12N | A12 Overhead Cranes - Transport to Site |  | 15d | 2011-09-11 | 2011-09-25 | P3A12M, P3A12L |  |  |  |  | -40d | 0d |  |  | TB26 - 2 - Manuf and Delivy |  |  | P3A12N | P3A12N | 860 | A12 | 00 | 2KB4740 | 200 | 200 | 400 | P | OWN | 0 | P | B | PB98 | LUZ2 | E | LND |  |  |
| P3A11N | A11 Unloading Arms - Transport to Site (collection of div. packages) |  | 25d | 2011-09-19 | 2011-10-13 | P3A11M |  |  |  |  | 0d |  | start on 2011-09-19 |  | TB26 - 2 - Manuf and Delivy |  |  | P3A11N | P3A11N | 860 | A11 | 00 | 2KB4420 | 200 | 200 | 400 | P | LND | 0 | P | B | PB98 | LUZ2 | E | LND |  |  |

Notes:
- P3A06AM: Expenses: 900A 11283
- P3A07N: P3 Activity Log Info: Rail
- P3A13M: Expenses: 900A 35582.4
- P3A11X: Expenses: 900A 43212
- P3A04AM: Expenses: 900A 296550
- P3A11M: Expenses: 900A 21606
- P3A16X: Expenses: 900A 114600
- P3A08X: Expenses: 900A 364200
- P3A01X: Expenses: 900A 123048
- P3A02CX: Expenses: 900A 37200
- P3A06X: Expenses: 900A 55920
- P3A17X: Expenses: 900A 0
- P3A08M: Expenses: 900A 182100
- P3A16M: Expenses: 900A 57300
- P3A02AX: Expenses: 900A 136380
- P3A08N: P3 Activity Log Info: Truck
- P3A16N: P3 Activity Log Info: Rail
- P3A02BX: Expenses: 900A 17272.5
- P3A02BM: Expenses: 900A 8636.25
- P3A01M: Expenses: 900A 61524
- P3A02CM: Expenses: 900A 18600
- P3A06M: Expenses: 900A 27960
- P3A17M: Expenses: 900A 0
- P3A02AM: Expenses: 900A 68190
- P3A12D: Expenses: 900A 0
- HPBA12: UDF_Actictity Name (Russia): Лифты (A12), заказ на поставку/изготовление/транспортировка на площадку
- P3A01N: P3 Activity Log Info: per Ship /Train
- P3A17N: P3 Activity Log Info: per / Truck/Train / Expenses: 900A 0
- P3A12M: Expenses: 900A 0
- P3A12N: Expenses: 900A 0

| ID | WBS | Activity | Type | Duration | Start | Finish | Predecessors | Complete | Total float | Free float | Constraint | Calendar | Cost | Actual cost | UDF_SAVE ACTID | UDF_SAVE ACT ID | Department | Type of Work | Constr. Area | Pro Unit/DocCode | Inquiry/Order No | PMT-Area | PMT-Schedule Org | PMT-Discipline | PMT-Phase | PMT-Respons. | Zeigen/n. Zeigen | WBS Phase | WBS Discipline | WBS Type of Work | WBS Objects | IMS | UPT | PMT-Doc. Type | PMT-Stage |
| --- | --- | --- | --- | --- | --- | --- | --- | --- | --- | --- | --- | --- | --- | --- | --- | --- | --- | --- | --- | --- | --- | --- | --- | --- | --- | --- | --- | --- | --- | --- | --- | --- | --- | --- | --- |
| P3A01N3 |  | A01 Drums/Small Vessels - Custom Clearance Period |  | 5d | 2011-10-04 | 2011-10-08 | P3A01N2 |  | 5d | 0d |  | TB26 - 2 - Manuf and Delivy |  |  | P3A02CN3 | P3A01N3 | 860 | A01 | 00 | DC | 2DD8530 | 200 | 200 | 400 | P | LND | C2 | P | B | PB48 | LUZ2 | E | LND |  |  |
| P3A02CN3 |  | A02C Instrument Air Vessels - Custom Clearance Period |  | 5d | 2011-10-04 | 2011-10-08 | P3A02CN2 |  | -82d | 0d |  | TB26 - 2 - Manuf and Delivy |  |  | P3A02CN3 | P3A02CN3 | 860 | A02C | 00 | DC | 2DD8530 | 200 | 200 | 400 | P | LND | C2 | P | B | PB48 | LUZ2 | E | LND |  |  |
| P3A06N3 |  | A06 Start-Up Heater/Condenser - Custom Clearance Period |  | 5d | 2011-10-04 | 2011-10-08 | P3A06N2 |  | -86d | 0d |  | TB26 - 2 - Manuf and Delivy |  |  | P3A06N3 | P3A06N3 | 860 | A06 | 00 | DC | 2DD8530 | 200 | 200 | 400 | P | LND | C2 | P | B | PB48 | LUZ2 | E | LND |  |  |
| P3A17N3 |  | A17 Teal S. C. Internal - Custom Clearance Period |  | 5d | 2011-10-04 | 2011-10-08 | P3A17N2 |  | 603.5d | 0d |  | TB26 - 2 - Manuf and Delivy |  |  | P3A17N3 | P3A17N3 | 860 | A17 | 00 | DC | 2DD8530 | 200 | 200 | 400 | P | LND | C2 | P | B | PB48 | LUZ2 | E | LND |  |  |
| P3M18X |  | M18 Pumps Chiller Unit - Final Inspection | milestone | 0d | 2011-12-13 | 2011-12-13 | E3M1860, P3M18L FF-43d, E3M1850 FF |  | 518.5d | 53d |  | TB26 - 2 - Manuf and Delivy |  |  | P3A02AX | P3M18X | 860 | M18 | 00 |  | 2PA6720 | 200 | 200 | 400 | P | LND |  | P | M | PB17 | LUZ2 | E | LND |  |  |
| P3A02DX |  | A02D Vessels Chiller Unit - Final Inspection | milestone | 0d | 2011-12-13 | 2011-12-13 | P3A02DL FF-43d, E3A02D60, E3A02D50 FF |  | 512.5d | 26d |  | TB26 - 2 - Manuf and Delivy |  |  | P3A02AX | P3A02DX | 860 | A02D | 00 |  | A02D | 200 | 200 | 400 | P | LND |  | P | B | PB17 | LUZ2 | E | LND |  |  |
| P3A02DM |  | A02D Vessels Chiller Unit - Goods deliv. FOB | milestone | 0d | 2012-01-11 | 2012-01-11 | P3A02DX FF, P3A02DL FF+10d |  | 486.5d | 0d |  | TB26 - 2 - Manuf and Delivy |  |  | P3A02AM | P3A02DM | 860 | A02D | 00 |  | A02D | 200 | 200 | 400 | P | LND |  | P | B | PB18 | LUZ2 | E | LND |  |  |
| P3A02DN |  | A02D Vessels Chiller Unit - Transport to Site |  | 25d | 2012-01-12 | 2012-02-05 | P3A02DM |  | 486.5d | 0d |  | TB26 - 2 - Manuf and Delivy |  |  | P3A02AN | P3A02DN | 860 | A02D | 00 |  | A02D | 200 | 200 | 400 | P | LND |  | P | B | PB18 | LUZ2 | E | LND |  |  |
| P3M18M |  | M18 Pumps Chiller Unit - Goods deliv. FOB | milestone | 0d | 2012-02-06 | 2012-02-06 | P3M18X FF, P3M18L FF+10d |  | 465.5d | 0d |  | TB26 - 2 - Manuf and Delivy |  |  | P3A02AM | P3M18M | 860 | M18 | 00 |  | 2PA6720 | 200 | 200 | 400 | P | LND |  | P | M | PB18 | LUZ2 | E | LND |  |  |
| P3M18N |  | M18 Pumps Chiller Unit - Transport to Site |  | 20d | 2012-02-07 | 2012-02-26 | P3M18M |  | 465.5d | 0d |  | TB26 - 2 - Manuf and Delivy |  |  | P3A02AN | P3M18N | 860 | M18 | 00 |  | 2PA6720 | 200 | 200 | 400 | P | LND |  | P | M | PB18 | LUZ2 | E | LND |  |  |
| P3A00S1 |  | A00 Mechanical Subcontract - Start Install Silo / Blenders | milestone | 0d | 2013-06-11 | 2013-06-11 | P3A00D |  | 0d |  | as late as possible |  |  |  | P3A00S1 | P3A00S1 | 860 | A00 | 00 |  | 2MD6880 | 200 | 200 | 400 | P | CC | 0 | P | B | PM11 | LUZ2 | SS | LND | DEV |  |
|  | M | **M Mechanical - Rotating Equipment** |  |  | 2007-12-20 | 2012-01-22 |  |  |  |  |  |  |  |  |  |  |  |  |  |  |  |  |  |  |  |  |  |  |  |  |  |  |  |  |  |
| F1540 |  | Inquieries LLI |  | 225d | 2007-12-20 A | 2008-11-13 A | F2760 | 100% |  |  |  |  |  |  | F1540 | F1540 | 860 |  | 00 |  |  | 200 | 200 |  | P |  |  | P | M | 0000 | LUZ2 | 1 | LND |  |  |
| P3M01A |  | M01 Extruder Pck. - Prepare Spec./Issue RFQ |  | 12d | 2007-12-20 A | 2008-01-11 A | F1660 SS, F1540 SS | 100% |  |  |  |  |  |  | P3M01A | P3M01A | 860 | M01 | 00 | DC | 2DC8480 | 200 | 200 | 400 | P | LND | C2 | P | M | PM31 | LUZ2 | INS | LND | DEV | 3A |
| F3410 |  | LOI Reactor Package | milestone | 0d | 2008-01-11 A | 2008-01-11 A | F2760 | 100% |  |  |  |  |  |  | F3410 | F3410 | 860 |  | 00 | 91 |  | 200 | 200 |  | P |  |  | P | M | 0000 | LUZ2 | PI | LND |  |  |
| F7500 |  | M01 Extruder Pck. - Issue RFQ to PMT | milestone | 0d | 2008-01-12 A | 2008-01-12 A | P3M01B FF | 100% |  |  |  |  |  |  | F7500 | F7500 | 860 | M01 | 00 |  | 2DC8480 | 200 | 200 | 400 | P | LND | C2 | P | M | PM31 | LUZ2 | 1 | LND |  | 3A |
| P3M01B |  | M01 Extruder Pck. - RFQ issued to bidders | milestone | 0d | 2008-01-12 A | 2008-01-12 A | P3M01A FF | 100% |  |  |  |  | 850,510 | 850,510 | P3M01B | P3M01B | 860 | M01 | 00 | DC | 2DC8480 | 200 | 200 | 400 | P | LND | C2 | P | M | PM31 | LUZ2 | INS | LND |  | 3A |
| F7160 |  | M01 Extruder Pck. - Vendor Bid Preparation |  | 27d | 2008-01-14 A | 2008-02-19 A | P3M01B | 100% |  |  |  |  |  |  | F7160 | F7160 | 860 | M01 | 00 | DC | 2DC8480 | 200 | 200 | 400 | P | LND | C2 | P | M | PM31 | LUZ2 | 1 | LND |  | 3A |
| F7510 |  | M01 Extruder Pck. - PMT approve RFQ |  | 19d | 2008-01-14 A | 2008-02-07 A | F7500 | 100% |  |  |  |  |  |  | F7510 | F7510 | 860 | M01 | 00 |  | 2DC8480 | 200 | 200 | 400 | P | PMT | C2 | P | M | PM31 | LUZ2 | 1 | LND |  | 3A |
| F4480 |  | Inquieries Equipment-critical for plant design |  | 207d | 2008-01-23 A | 2008-11-14 A | F2760 | 100% |  |  |  |  |  |  | F4480 | F4480 | 860 |  | 00 |  |  | 200 | 200 |  | P |  |  | P | M | 0000 | LUZ2 |  | LND |  |  |
| P3M06A |  | M06 R. Tepid Pumps - PrepareSpec./Issue RFQ |  | 10d | 2008-01-24 A | 2008-02-06 A | F1660 SS+20d, F1540 SS | 100% |  |  |  |  |  |  | P3M06A | P3M06A | 860 | M06 | 00 | DC | 2PA6540 | 200 | 200 | 400 | P | LND | C2 | P | M | PM21 | LUZ2 | E | LND | DEV |  |
| F4510 |  | Bid Tab/ Vendor Recommendation LLI |  | 244d | 2008-01-25 A | 2009-01-16 A | F4490 FF+20d | 100% |  |  |  |  |  |  | F4510 | F4510 | 860 |  | 00 |  |  | 200 | 200 |  | P |  |  | P | M | 0000 | LUZ2 |  | LND |  |  |
| P3M05A |  | M05 R. Quench Pumps - Prepare Spec./Issue RFQ |  | 9d | 2008-01-25 A | 2008-02-06 A | F1660 SS+20d, F1540 SS+15d | 100% |  |  |  |  |  |  | P3M05A | P3M05A | 860 | M05 | 00 | DC | 2PA6550 | 200 | 200 | 400 | P | LND | C2 | P | M | PM21 | LUZ2 | E | LND | DEV |  |
| P3M11A |  | M11 RA Gear Unit - Prepare/Issue RFQ |  | 31d | 2008-02-01 A | 2008-03-14 A | F1660 SS+20d, F1540 SS | 100% |  |  |  |  |  |  | P3M11A | P3M11A | 860 | M11 | 00 | DC | 2KB4290 | 200 | 200 | 400 | P | LND | C2 | P | M | PM91 | LUZ2 | E | LND | DEV | 3A |
| F7410 |  | M06 R. Tepid Pumps - Issue RFQ to PMT | milestone | 0d | 2008-02-07 A | 2008-02-07 A | P3M06B FF | 100% |  |  |  |  |  |  | F7410 | F7410 | 860 | M06 | 00 |  | 2PA6540 | 200 | 200 | 400 | P | LND | C2 | P | M | PM21 | LUZ2 | 1 | LND |  |  |
| F7420 |  | M06 R. Tepid Pumps - PMT approve RFQ |  | 5d | 2008-02-07 A | 2008-02-13 A | F7410 | 100% |  |  |  |  |  |  | F7420 | F7420 | 860 | M06 | 00 |  | 2PA6540 | 200 | 200 | 400 | P | PMT | C2 | P | M | PM21 | LUZ2 | 1 | LND |  |  |
| F7710 |  | M05 R. Quench Pumps - Issue RFQ to PMT | milestone | 0d | 2008-02-07 A | 2008-02-07 A | P3M05B FF | 100% |  |  |  |  |  |  | F7710 | F7710 | 860 | M05 | 00 |  | 2PA6550 | 200 | 200 | 400 | P | LND | C2 | P | M | PM21 | LUZ2 | 1 | LND |  |  |
| F7720 |  | M05 R. Quench Pumps - PMT approve RFQ |  | 5d | 2008-02-07 A | 2008-02-13 A | F7710 | 100% |  |  |  |  |  |  | F7720 | F7720 | 860 | M05 | 00 |  | 2PA6550 | 200 | 200 | 400 | P | PMT | C2 | P | M | PM21 | LUZ2 | 1 | LND |  |  |
| P3M05B |  | M05 R. Quench Pumps - RFQ issued to bidders | milestone | 0d | 2008-02-07 A | 2008-02-07 A | P3M05A FF | 100% |  |  |  |  | 58,089.7 | 58,089.7 | P3M05B | P3M05B | 860 | M05 | 00 | DC | 2PA6550 | 200 | 200 | 400 | P | LND | C2 | P | M | PM21 | LUZ2 | E | LND |  |  |
| P3M06B |  | M06 R. Tepid Pumps - RFQ issued to bidders | milestone | 0d | 2008-02-07 A | 2008-02-07 A | P3M06A FF | 100% |  |  |  |  | 9,449 | 9,449 | P3M06B | P3M06B | 860 | M06 | 00 | DC | 2PA6540 | 200 | 200 | 400 | P | LND | C2 | P | M | PM21 | LUZ2 | E | LND |  |  |
| F2930 |  | Purchase Order LLI | level of effort | 145d | 2008-02-08 A | 2008-09-03 A | F4990 SS | 100% |  |  |  |  |  |  | F2930 | F2930 | 860 |  | 00 | 91 |  | 200 | 200 |  | P |  |  | P | M | 0000 | LUZ2 | C | LND |  |  |
| F7600 |  | M05 R. Quench Pumps - Vendor Bid Preparation |  | 60d | 2008-02-11 A | 2008-05-07 A | P3M05B | 100% |  |  |  |  |  |  | F7600 | F7600 | 860 | M05 | 00 | DC | 2PA6550 | 200 | 200 | 400 | P | LND | C2 | P | M | PM21 | LUZ2 | 1 | LND |  |  |
| F4530 |  | Purchase Order LLI |  | 242d | 2008-02-12 A | 2009-01-30 A | F4510 FF+3d | 100% |  |  |  |  |  |  | F4530 | F4530 | 860 |  | 00 |  |  | 200 | 200 |  | P |  |  | P | M | 0000 | LUZ2 |  | LND |  |  |
| F7300 |  | M06 R. Tepid Pumps - Vendor Bid Preparation |  | 57d | 2008-02-14 A | 2008-05-07 A | P3M06B | 100% |  |  |  |  |  |  | F7300 | F7300 | 860 | M06 | 00 | DC | 2PA6540 | 200 | 200 | 400 | P | LND | C2 | P | M | PM21 | LUZ2 | 1 | LND |  |  |
| F7520 |  | M01 Extruder Pck. - Vendor Bid for INEOS Review | milestone | 0d | 2008-02-20 A | 2008-02-20 A | F7510, F7160 | 100% |  |  |  |  |  |  | F7520 | F7520 | 860 | M01 | 00 |  | 2DC8480 | 200 | 200 | 400 | P | LND | C2 | P | M | PM31 | LUZ2 | 1 | LND |  | 3A |
| P3M01C |  | M01 Extruder Pck. - Eval./Negotiation |  | 38d | 2008-03-03 A | 2008-04-25 A | F7220 | 100% |  |  |  |  |  |  | P3M01C | P3M01C | 860 | M01 | 00 | DC | 2DC8480 | 200 | 200 | 400 | P | LND | C2 | P | M | PM32 | LUZ2 | INS | LND |  | 3A |
| P3M08A |  | M08 Teal/Donor Feed Pumps - Prepare/Issue RFQ |  | 5d | 2008-03-03 A | 2008-03-07 A | E3M0810 | 100% |  |  |  |  |  |  | P3M08A | P3M08A | 860 | M08 | 00 |  | 2PA6690 | 200 | 200 | 400 | P | LND | 1 | P | M | PM21 | LUZ2 | E | LND | DEV |  |
| P3M08B |  | M08 Teal/Donor Feed Pumps - RFQ issued | milestone | 0d | 2008-03-08 A | 2008-03-08 A | P3M08A FF | 100% |  |  |  |  | 5,147.65 | 5,147.65 | P3M08B | P3M08B | 860 | M08 | 00 |  | 2PA6690 | 200 | 200 | 400 | P | LND | 1 | P | M | PM21 | LUZ2 | E | LND | DEV |  |
| F6870 |  | M11 RA Gear Unit - Issue RFQ to PMT | milestone | 0d | 2008-03-15 A | 2008-03-15 A | P3M11A FF | 100% |  |  |  |  |  |  | F6870 | F6870 | 860 | M11 | 00 |  | 2KB4290 | 200 | 200 | 400 | P | LND | C2 | P | M | PM91 | LUZ2 | 1 | LND |  | 3A |
| P3M11B |  | M11 RA Gear Unit - RFQ issued to bidders | milestone | 0d | 2008-03-15 A | 2008-03-15 A | P3M11A FF | 100% |  |  |  |  | 57,045 | 57,045 | P3M11B | P3M11B | 860 | M11 | 00 | DC | 2KB4290 | 200 | 200 | 400 | P | LND | C2 | P | M | PM91 | LUZ2 | E | LND |  | 3A |
| F6880 |  | M11 RA Gear Unit - PMT approve RFQ |  | 4d | 2008-03-17 A | 2008-03-20 A | F6870 | 100% |  |  |  |  |  |  | F6880 | F6880 | 860 | M11 | 00 |  | 2KB4290 | 200 | 200 | 400 | P | PMT | C2 | P | M | PM91 | LUZ2 | 1 | LND |  | 3A |
| F6760 |  | M11 RA Gear Unit - Vendor Bid Preparation |  | 26d | 2008-03-25 A | 2008-04-29 A | P3M11B FS+10d | 100% |  |  |  |  |  |  | F6760 | F6760 | 860 | M11 | 00 | DC | 2KB4290 | 200 | 200 | 400 | P | LND | C2 | P | M | PM91 | LUZ2 | 1 | LND |  | 3A |
| F7990 |  | M01 Extruder Pck. - Bid tab Client appr. |  | 4d | 2008-04-22 A | 2008-04-25 A | E3M0130, P3M01C FF | 100% |  |  |  |  |  |  | F7990 | F7990 | 860 | M01 | 00 |  | 2DC8480 | 200 | 200 | 400 | P | PMT | C2 | P | M | PM32 | LUZ2 | 1 | LND |  | 3A |
| P3M12A |  | M12 Rotary Feeder - Prepare/Issue RFQ |  | 5d | 2008-04-24 A | 2008-04-30 A | E3M1210 | 100% |  |  |  |  |  |  | P3M12A | P3M12A | 860 | M12 | 00 |  | 2DC8940 | 200 | 200 | 400 | P | LND | 0 | P | M | PM91 | LUZ2 | E | LND | DEV |  |
| P3M01D |  | M01 Extruder Pck. - PO issued | milestone | 0d | 2008-04-26 A | 2008-04-26 A | F7990 FF, F2930 FF, E3M0120 | 100% |  |  |  |  | 3,402,040 | 3,402,040 | P3M01D | P3M01D | 860 | M01 | 00 | DC | 2DC8480 | 200 | 200 |  | P | LND | C2 | P | M | PM33 | LUZ2 | INS | LND |  |  |
| HPMM01 |  | Extruder Pck. (M01) PO/Fabr./Transport to Site | level of effort | 745d | 2008-04-28 A | 2011-04-12 A | P3M01L SS | 100% |  |  |  |  |  |  | HPMM01 | HPMM01 | 867 |  | 00 |  |  | 200 | 200 | 400 | E | LND | L2 | P | M | PM93 | LUZ2 | E | LND | DFA |  |
| F6890 |  | M11 RA Gear Unit - Vendor Bid for INEOS Review | milestone | 0d | 2008-04-30 A | 2008-04-30 A | F6880, F6760 | 100% |  |  |  |  |  |  | F6890 | F6890 | 860 | M11 | 00 |  | 2KB4290 | 200 | 200 | 400 | P | LND | C2 | P | M | PM92 | LUZ2 | 1 | LND |  | 3A |
| P3M12B |  | M12 Rotary Feeder - RFQ issued | milestone | 0d | 2008-05-01 A | 2008-05-01 A | P3M12A FF | 100% |  |  |  |  | 38,950.5 | 38,950.5 | P3M12B | P3M12B | 860 | M12 | 00 |  | 2DC8940 | 200 | 200 | 400 | P | LND | 0 | P | M | PM91 | LUZ2 | E | LND | DEV |  |
| F7430 |  | M06 R.Tepid Pumps- Vendor Bid for INEOS Review | milestone | 0d | 2008-05-08 A | 2008-05-08 A | F7300, F7420 | 100% |  |  |  |  |  |  | F7430 | F7430 | 860 | M06 | 00 |  | 2PA6540 | 200 | 200 | 400 | P | LND | C2 | P | M | PM22 | LUZ2 | 1 | LND |  |  |
| F7730 |  | M05 R. Quench Pumps- Vendor Bid for INEOS Review | milestone | 0d | 2008-05-08 A | 2008-05-08 A | F7600, F7720 | 100% |  |  |  |  |  |  | F7730 | F7730 | 860 | M05 | 00 |  | 2PA6550 | 200 | 200 | 400 | P | LND | C2 | P | M | PM22 | LUZ2 | 1 | LND |  |  |
| P3M07A |  | M07 Catalyst Feed Pumps - Prepare/Issue RFQ |  | 5d | 2008-05-20 A | 2008-05-26 A | E3M0710 | 100% |  |  |  |  |  |  | P3M07A | P3M07A | 860 | M07 | 00 |  | 2PA6670 | 200 | 200 | 400 | P | LND | 0 | P | M | PM21 | LUZ2 | E | LND | DEV |  |
| P3M11C |  | M11 RA Gear Unit - Eval./Negotiation |  | 92d | 2008-05-22 A | 2008-09-26 A | F6810 FS+5d | 100% |  |  |  |  |  |  | P3M11C | P3M11C | 860 | M11 | 00 | DC | 2KB4290 | 200 | 200 | 400 | P | LND | C2 | P | M | PM92 | LUZ2 | E | LND |  | 3A |
| F4540 |  | Purchase Order Design Critical Equipment |  | 183d | 2008-05-23 A | 2009-02-13 A | F4520 FF+15d, F4530 FF | 100% |  |  |  |  |  |  | F4540 | F4540 | 860 |  | 00 |  |  | 200 | 200 |  | P |  |  | P | M | 0000 | LUZ2 |  | LND |  |  |
| P3M05C |  | M05 R. Quench Pumps - Eval./Negotiation |  | 105d | 2008-05-23 A | 2008-10-17 A | F7650 FS+5d | 100% |  |  |  |  |  |  | P3M05C | P3M05C | 860 | M05 | 00 | DC | 2PA6550 | 200 | 200 | 400 | P | LND | C2 | P | M | PM22 | LUZ2 | E | LND |  |  |
| P3M06C |  | M06 R. Tepid Pumps - Eval./Negotiation |  | 56d | 2008-05-23 A | 2008-08-08 A | F7350 FS+5d | 100% |  |  |  |  |  |  | P3M06C | P3M06C | 860 | M06 | 00 | DC | 2PA6540 | 200 | 200 | 400 | P | LND | C2 | P | M | PM22 | LUZ2 | E | LND |  |  |
| P3M10A |  | M10 Catalyst Waste Pumps - Prepare/Issue RFQ |  | 3d | 2008-05-23 A | 2008-05-27 A | E3M1010 | 100% |  |  |  |  |  |  | P3M10A | P3M10A | 860 | M10 | 00 |  | 2PA6690 | 200 | 200 | 400 | P | LND | 1 | P | M | PM21 | LUZ2 | E | LND | DEV |  |
| HPMM03 |  | Offgas Compr. (M03) PO/Fabr./Transport to Site | level of effort | 661d | 2008-05-26 A | 2011-01-10 A | P3M03L SS | 100% |  |  |  |  |  |  | HPMM03 | HPMM03 | 867 |  | 00 |  |  | 200 | 200 | 400 | E | LND | L2 | P | M | PM93 | LUZ2 | E | LND | DFA |  |
| P3M07B |  | M07 Catalyst Feed Pumps - RFQ issued | milestone | 0d | 2008-05-27 A | 2008-05-27 A | P3M07A FF | 100% |  |  |  |  | 8,737.65 | 8,737.65 | P3M07B | P3M07B | 860 | M07 | 00 |  | 2PA6670 | 200 | 200 | 400 | P | LND | 0 | P | M | PM21 | LUZ2 | E | LND | DEV |  |
| P3M10B |  | M10 Catalyst Waste Pumps - RFQ issued | milestone | 0d | 2008-05-28 A | 2008-05-28 A | P3M10A FF | 100% |  |  |  |  | 2,704.9 | 2,704.9 | P3M10B | P3M10B | 860 | M10 | 00 |  | 2PA6690 | 200 | 200 | 400 | P | LND | 1 | P | M | PM21 | LUZ2 | E | LND | DEV |  |
| HPMM02 |  | RecycleG.Compr. (M02) PO/Fabr./Transport to Site | level of effort | 648d | 2008-05-29 A | 2010-12-23 A | P3M02L SS | 100% |  |  |  |  |  |  | HPMM02 | HPMM02 | 867 |  | 00 |  |  | 200 | 200 | 400 | E | LND | L2 | P | M | PM93 | LUZ2 | E | LND | DFA |  |
| P3M09A |  | M09 Unloading Pumps - Prepare/Issue RFQ |  | 3d | 2008-06-06 A | 2008-06-10 A | E3M0910 | 100% |  |  |  |  |  |  | P3M09A | P3M09A | 860 | M09 | 00 |  | 2PA6680 | 200 | 200 | 400 | P | LND | 1 | P | M | PM21 | LUZ2 | E | LND | DEV |  |
| P3M09B |  | M09 Unloading Pumps - RFQ issued | milestone | 0d | 2008-06-11 A | 2008-06-11 A | P3M09A FF | 100% |  |  |  |  | 1,500 | 1,500 | P3M09B | P3M09B | 860 | M09 | 00 |  | 2PA6680 | 200 | 200 | 400 | P | LND | 1 | P | M | PM21 | LUZ2 | E | LND | DEV |  |
| P3M08C |  | M08 Teal/Donor Feed Pumps - Eval./Negotiation |  | 83d | 2008-07-21 A | 2008-11-14 A | E3M0820 FF, P3M08B | 100% |  |  |  |  |  |  | P3M08C | P3M08C | 860 | M08 | 00 |  | 2PA6690 | 200 | 200 | 400 | P | LND | 1 | P | M | PM22 | LUZ2 | E | LND |  |  |
| P3M10C |  | M10 Catalyst Waste Pumps - Eval./Negotiation |  | 83d | 2008-07-21 A | 2008-11-14 A | P3M10B, E3M1020 FF | 100% |  |  |  |  |  |  | P3M10C | P3M10C | 860 | M10 | 00 |  | 2PA6690 | 200 | 200 | 400 | P | LND | 1 | P | M | PM22 | LUZ2 | E | LND |  |  |
| F7480 |  | M06 R. Tepid Pumps - Bid tab Client appr. |  | 13d | 2008-07-23 A | 2008-08-08 A | E3M0630, P3M06C FF | 100% |  |  |  |  |  |  | F7480 | F7480 | 860 | M06 | 00 |  | 2PA6540 | 200 | 200 | 400 | P | PMT | C2 | P | M | PM22 | LUZ2 | 1 | LND |  |  |
| F7780 |  | M05 R. Quench Pumps - Bid tab Client appr./VA |  | 53d | 2008-07-23 A | 2008-10-06 A | E3M0530, P3M05C FF | 100% |  |  |  |  |  |  | F7780 | F7780 | 860 | M05 | 00 |  | 2PA6550 | 200 | 200 | 400 | P | PMT | C2 | P | M | PM22 | LUZ2 | 1 | LND |  |  |
| P3M12C |  | M12 Rotary Feeder - Eval./Negotiation |  | 118d | 2008-07-24 A | 2009-01-15 A | P3M12B, E3M1220 FF | 100% |  |  |  |  |  |  | P3M12C | P3M12C | 860 | M12 | 00 |  | 2DC8940 | 200 | 200 | 400 | P | LND | 0 | P | M | PM92 | LUZ2 | E | LND |  |  |
| F6940 |  | M11 RA Gear Unit - Bid tab Client appr./VA |  | 30d | 2008-08-08 A | 2008-09-18 A | P3M11C FF, E3M1130 | 100% |  |  |  |  |  |  | F6940 | F6940 | 860 | M11 | 00 |  | 2KB4290 | 200 | 200 | 400 | P | PMT | C2 | P | M | PM92 | LUZ2 | 1 | LND |  | 3A |
| P3M06D1 |  | M06 R. Tepid Pumps - PO issued (Engineering) | milestone | 0d | 2008-08-09 A | 2008-08-09 A | F7480 FF, P3M06C FF, E3M0620 | 100% |  |  |  |  |  |  | P3M06D1 | P3M06D1 | 860 | M06 | 00 | DC | 2PA6540 | 200 | 200 | 400 | P | LND | C2 | P | M | PM23 | LUZ2 | E | LND |  |  |
| P3M06L |  | M06 R. Tepid Pumps - Lead Time/Fabrication |  | 836d | 2008-08-09 A | 2010-11-30 A | P3M06D1 | 100% |  |  |  | TB26 - 2 - Manuf and Delivy |  |  | P3M06L | P3M06L | 860 | M06 | 00 | DC | 2PA6540 | 200 | 200 | 400 | P | LND | C2 | P | M | PM26 | LUZ2 | E | LND | DEL |  |

Notes:
- P3M01B: Expenses: 900A 850510
- P3M05B: Expenses: 900A 58089.7
- P3M06B: Expenses: 900A 9449
- P3M08B: Expenses: 900A 5147.65
- P3M11B: Expenses: 900A 57045
- P3M01D: Expenses: 900A 3402040
- HPMM01: UDF_Actictity Name (Russia): Комплектная установка экструдера (M01), заказ на поставку/изготовление/транспортировка на площадку
- P3M12B: Expenses: 900A 38950.5
- HPMM03: UDF_Actictity Name (Russia): Компрессор отходящего газа (M03), заказ на поставку/изготовление/транспортировка на площадку
- P3M07B: Expenses: 900A 8737.65
- P3M10B: Expenses: 900A 2704.9
- HPMM02: UDF_Actictity Name (Russia): Компрессор рециркулирующего газа (M02), заказ на поставку/изготовление/транспортировка на площадку
- P3M09B: Expenses: 900A 1500

| ID | Activity | Type | Duration | Start | Finish | Predecessors | Complete | Calendar | Cost | Actual cost | UDF_SAVE ACTID | UDF_SAVE ACT ID | Department | Constr. Area | Pro Unit/DocCode | PMT-Area | PMT-Phase | WBS Phase | WBS Discipline | WBS Type of Work | WBS Objects | IMS | UPT | PMT-Schedule Org | PMT-Discipline | PMT-Doc. Type | PMT-Respons. | Zeigen/n. Zeigen | Type of Work | Inquiry/Order No | PMT-Stage |
| --- | --- | --- | --- | --- | --- | --- | --- | --- | --- | --- | --- | --- | --- | --- | --- | --- | --- | --- | --- | --- | --- | --- | --- | --- | --- | --- | --- | --- | --- | --- | --- |
| F2940 | P.O.'s Other Equipment | level of effort | 715d | 2008-08-11 A | 2011-06-10 A | P3A01L SS, P3A03L SS, P3M14L SS, P3A18L SS, P3U05L SS, P3A06L SS, P3A17L SS, P3A06AL SS, P3M15L SS, P3M05L SS, P3U15L SS, P3U22L SS, F3080 SS+3d, P3M12L SS, P3M06L SS | 100% |  |  |  | F2940 | F2940 | 860 | 00 | 91 | 200 | P | P | M | 0000 | LUZ2 | P | LND |  |  |  |  |  |  |  |  |
| HPMM06 | Tepid Pumps (M06) PO/Fabr./Transport to Site | level of effort | 618d | 2008-08-11 A | 2011-01-26 A | P3M06L SS | 100% |  |  |  | HPMM06 | HPMM06 | 867 | 00 |  | 200 | E | P | M | PM93 | LUZ2 | E | LND | 200 | 400 | DFA | LND | L2 |  |  |  |
| P3M07C | M07 Catalyst Feed Pumps - Eval./Negotiation |  | 53d | 2008-08-20 A | 2008-11-04 A | E3M0720 FF, P3M07B | 100% |  |  |  | P3M07C | P3M07C | 860 | 00 |  | 200 | P | P | M | PM22 | LUZ2 | E | LND | 200 | 400 |  | LND | 0 | M07 | 2PA6670 |  |
| HPMM04 | GasBleed Compr. (M04) PO/Fabr./Transport to Site | level of effort | 687d | 2008-09-04 A | 2011-05-27 A | P3M04L SS | 100% |  |  |  | HPMM04 | HPMM04 | 867 | 00 |  | 200 | E | P | M | PM93 | LUZ2 | E | LND | 200 | 400 | DFA | LND | L2 |  |  |  |
| P3M06D2 | M06 R. Tepid Pumps - PO issued (Equipment) | milestone | 0d | 2008-09-10 A | 2008-09-10 A | P3M06D1 FF+30d | 100% |  | 37,796 | 37,796 | P3M06D2 | P3M06D2 | 860 | 00 | DC | 200 | P | P | M | PM23 | LUZ2 | E | LND | 200 | 400 |  | LND | C2 | M06 | 2PA6540 |  |
| P3M11D | M11 RA Gear Unit - PO issued | milestone | 0d | 2008-09-27 A | 2008-09-27 A | F6940 FF, P3M11C FF, F2920 FF | 100% |  | 228,180 | 228,180 | P3M11D | P3M11D | 860 | 00 | DC | 200 | P | P | M | PM93 | LUZ2 | E | LND | 200 | 400 |  | LND | C2 | M11 | 2KB4290 | 3A |
| P3M11L | M11 RA Gear Unit - Lead Time/Fabrication |  | 871d | 2008-09-27 A | 2011-02-25 A | P3M11D | 100% | TB26 - 2 - Manuf and Delivy |  |  | P3M11L | P3M11L | 860 | 00 | DC | 200 | P | P | M | PM96 | LUZ2 | E | LND | 200 | 400 | DEL | LND | C2 | M11 | 2KB4290 |  |
| P3M07F | M07 Catalyst Feed Pumps - Bid tab Client appr. |  | 22d | 2008-09-29 A | 2008-10-29 A | E3M0730 | 100% |  |  |  | P3M07F | P3M07F | 860 | 00 |  | 200 | P | P | M | PM22 | LUZ2 | P | LND | 200 | 400 |  | PMT | 0 | M07 | 2PA6670 |  |
| P3M12F | M12 Rotary Feeder - Bid tab Client appr. |  | 59d | 2008-10-07 A | 2009-01-06 A | E3M1230 | 100% |  |  |  | P3M12F | P3M12F | 860 | 00 |  | 200 | P | P | M | PM22 | LUZ2 | P | LND | 200 | 400 |  | PMT | 0 | M12 | 2DC8940 |  |
| P3M05D | M05 R. Quench Pumps - PO issued | milestone | 0d | 2008-10-18 A | 2008-10-18 A | F7780 FF, P3M05C FF, E3M0520 | 100% |  | 232,358.8 | 232,358.8 | P3M05D | P3M05D | 860 | 00 | DC | 200 | P | P | M | PM23 | LUZ2 | E | LND | 200 | 400 |  | LND | C2 | M05 | 2PA6550 |  |
| P3M05L | M05 R. Quench Pumps - Lead Time/Fabrication |  | 766d | 2008-10-18 A | 2010-11-30 A | P3M05D | 100% | TB26 - 2 - Manuf and Delivy |  |  | P3M05L | P3M05L | 860 | 00 | DC | 200 | P | P | M | PM26 | LUZ2 | E | LND | 200 | 400 | DEL | LND | C2 | M05 | 2PA6550 |  |
| HPMM05 | Quench Pumps (M05) PO/Fabr./Transport to Site | level of effort | 569d | 2008-10-20 A | 2011-01-26 A | P3M05L SS | 100% |  |  |  | HPMM05 | HPMM05 | 867 | 00 |  | 200 | E | P | M | PM93 | LUZ2 | E | LND | 200 | 400 | DFA | LND | L2 |  |  |  |
| P3M08F | M08 Teal/Donor Feed Pump - Bid tab Client appr. |  | 50d | 2008-10-22 A | 2009-01-08 A | E3M0830 | 100% |  |  |  | P3M08F | P3M08F | 860 | 00 |  | 200 | P | P | M | PM22 | LUZ2 | P | LND | 200 | 400 |  | PMT | 0 | M08 | 2PA6690 |  |
| P3M10F | M10 Catalyst Waste Pumps - Bid tab Client appr. |  | 50d | 2008-10-22 A | 2009-01-08 A | E3M1030 | 100% |  |  |  | P3M10F | P3M10F | 860 | 00 |  | 200 | P | P | M | PM22 | LUZ2 | P | LND | 200 | 400 |  | PMT | 0 | M10 | 2PA6690 |  |
| F3980 | Bid Tabulation Itemized Equipment |  | 59d | 2008-11-03 A | 2009-01-30 A | F4480 SS | 100% |  |  |  | F3980 | F3980 | 860 | 00 |  | 200 | P | P | M | 0000 | LUZ2 | PI | LND |  |  |  |  | 3 |  |  |  |
| HPMM07 | Catalyst F.Pumps(M07) PO/Fabr./Transport to Site | level of effort | 665d | 2008-11-05 A | 2011-06-24 A | P3M07L SS | 100% |  |  |  | HPMM07 | HPMM07 | 867 | 00 |  | 200 | E | P | M | PM93 | LUZ2 | E | LND | 200 | 400 | DFA | LND | L2 |  |  |  |
| P3M07D1 | M07 Catalyst Feed Pumps- PO issued (Engineering) | milestone | 0d | 2008-11-05 A | 2008-11-05 A | P3M07F FF, P3M07C FF, E3M0730 FF | 100% |  |  |  | P3M07D1 | P3M07D1 | 860 | 00 |  | 200 | P | P | M | PM23 | LUZ2 | E | LND | 200 | 400 |  | LND | 0 | M07 | 2PA6670 |  |
| P3M07L | M07 Catalyst Feed Pumps - Lead Time/Fabrication |  | 807d | 2008-11-05 A | 2011-01-31 A | P3M07D1 | 100% | TB26 - 2 - Manuf and Delivy |  |  | P3M07L | P3M07L | 860 | 00 |  | 200 | P | P | M | PM26 | LUZ2 | E | LND | 200 | 400 | DEL | LND | 0 | M07 | 2PA6670 |  |
| P3M09C | M09 Unloading Pumps - Eval./Negotiation |  | 426d | 2008-11-10 A | 2010-07-26 A | P3M09B, E3M0920 FF | 100% |  |  |  | P3M09C | P3M09C | 860 | 00 |  | 200 | P | P | M | PM22 | LUZ2 | E | LND | 200 | 400 |  | LND | 1 | M09 | 2PA6680 |  |
| F4520 | Bid Tab/ Vendor Recommend. DC Equipment |  | 44d | 2008-11-17 A | 2009-01-23 A | F4500 FF+3d | 100% |  |  |  | F4520 | F4520 | 860 | 00 |  | 200 | P | P | M | 0000 | LUZ2 |  | LND | 200 |  |  |  |  |  |  |  |
| P3M09F | M09 Unloading Pumps - Bid tab Client appr. |  | 403d | 2008-11-28 A | 2010-07-12 A | E3M0930 | 100% |  |  |  | P3M09F | P3M09F | 860 | 00 |  | 200 | P | P | M | PM22 | LUZ2 | E | PMT | 200 | 400 |  | PMT | 0 | M09 | 2PA6680 |  |
| F3290 | P.O.'s LLI -rotating equipment by Contractor | milestone | 0d | 2009-01-03 A | 2009-01-03 A | F3330 FF+11d | 100% |  |  |  | F3290 | F3290 | 860 | 00 |  | 200 | P | P | M | 0000 | LUZ2 | PI | LND | 200 |  |  |  | 3 |  |  |  |
| HPM20 | Rotating Eqpt - Remaining Engineering PO's |  | 201d | 2009-01-15 A | 2009-10-29 A | P3M12D1 FF, F3290 | 100% |  |  |  | HPM20 | HPM20 | 869 | 00 |  | 200 | E | P | M | PM93 | LUZ2 | INS | LND | 200 | 400 | DFA | LND | L2 |  |  |  |
| P3M12D1 | M12 Rotary Feeder - PO issued (Engineering) | milestone | 0d | 2009-01-16 A | 2009-01-16 A | P3M12F FF, P3M12C FF, E3M1230 FF | 100% |  |  |  | P3M12D1 | P3M12D1 | 860 | 00 |  | 200 | P | P | M | PM93 | LUZ2 | E | LND | 200 | 400 |  | LND | 0 | M12 | 2DC8940 |  |
| P3M16A | M16 Instrument Air Compr. - Prepare/Issue RFQ |  | 9d | 2009-02-23 A | 2009-03-05 A | E3M1610 | 100% |  |  |  | P3M16A | P3M16A | 860 | 00 |  | 200 | P | P | M | PM11 | LUZ2 | E | LND | 200 | 400 | DEV | LND | 0 | M16 | 2KB4660 |  |
| P3M14A | M14 Submers. Pumps - Prepare/Issue RFQ |  | 7d | 2009-02-25 A | 2009-03-05 A | E3M1410 | 100% |  |  |  | P3M14A | P3M14A | 860 | 00 |  | 200 | P | P | M | PM91 | LUZ2 | E | LND | 200 | 400 | DEV | LND | 0 | M14 | 2PA6900 |  |
| P3M15A | M15 Conds./BoosterP. - Prepare/Issue RFQ |  | 7d | 2009-02-25 A | 2009-03-05 A | E3M1510 | 100% |  |  |  | P3M15A | P3M15A | 860 | 00 |  | 200 | P | P | M | PM91 | LUZ2 | E | LND | 200 | 400 | DEV | LND | 0 | M15 | 2PA6720 |  |
| P3M14B | M14 Submers. Pumps - RFQ issued | milestone | 0d | 2009-03-06 A | 2009-03-06 A | P3M14A FF | 100% |  | 2,450 | 2,450 | P3M14B | P3M14B | 860 | 00 |  | 200 | P | P | M | PM91 | LUZ2 | E | LND | 200 | 400 | DEV | LND | 0 | M14 | 2PA6900 |  |
| P3M15B | M15 Conds./BoosterP. - RFQ issued | milestone | 0d | 2009-03-06 A | 2009-03-06 A | P3M15A FF | 100% |  | 5,100 | 5,100 | P3M15B | P3M15B | 860 | 00 |  | 200 | P | P | M | PM91 | LUZ2 | E | LND | 200 | 400 | DEV | LND | 0 | M15 | 2PA6720 |  |
| P3M16B | M16 Instrument Air Compr. - RFQ issued | milestone | 0d | 2009-03-06 A | 2009-03-06 A | P3M16A FF | 100% |  | 16,528.8 | 16,528.8 | P3M16B | P3M16B | 860 | 00 |  | 200 | P | P | M | PM11 | LUZ2 | E | LND | 200 | 400 | DEV | LND | 0 | M16 | 2KB4660 |  |
| F2920 | Purchase Order Design Critical Equipment | level of effort | 134d | 2009-04-01 A | 2009-10-12 A | F4480 SS | 100% |  |  |  | F2920 | F2920 | 860 | 00 | 91 | 200 | P | P | M | 0000 | LUZ2 | C | LND | 200 |  |  |  |  |  |  |  |
| F2890 | P.O.'s LLI -static equipment by Contractor | milestone | 0d | 2009-04-01 A | 2009-04-01 A | F4480 FF | 100% |  |  |  | F2890 | F2890 | 860 | 00 | 91 | 200 | P | P | M | 0000 | LUZ2 | C | LND | 200 |  |  |  | 3 |  |  |  |
| P3M16C | M16 Instrument Air Compr. - Eval./Negotiation |  | 132d | 2009-08-14 A | 2010-02-22 A | P3M16B, E3M1620 FF | 100% |  |  |  | P3M16C | P3M16C | 860 | 00 |  | 200 | P | P | M | PM12 | LUZ2 | E | LND | 200 | 400 |  | LND | 0 | M16 | 2KB4660 |  |
| P3M08D1 | M08 Teal/Donor Feed Pumps - PO issued (Engin.) | milestone | 0d | 2009-09-01 A | 2009-09-01 A | P3M08F FS+158d | 100% |  |  |  | P3M08D1 | P3M08D1 | 860 | 00 |  | 200 | P | P | M | PM23 | LUZ2 | E | LND | 200 | 400 |  | LND | 1 | M08 | 2PA6690 |  |
| P3M10D1 | M10 Catalyst Waste Pumps - PO issued (Engin.) | milestone | 0d | 2009-09-01 A | 2009-09-01 A | P3M10F FS+158d | 100% |  |  |  | P3M10D1 | P3M10D1 | 860 | 00 |  | 200 | P | P | M | PM23 | LUZ2 | E | LND | 200 | 400 |  | LND | 1 | M10 | 2PA6690 |  |
| P3M15C | M15 Conds./BoosterP. - Eval./Negotiation |  | 112d | 2009-10-30 A | 2010-04-14 A | P3M15B, E3M1520 FF | 100% |  |  |  | P3M15C | P3M15C | 860 | 00 |  | 200 | P | P | M | PM92 | LUZ2 | E | LND | 200 | 400 |  | LND | 0 | M15 | 2PA6720 |  |
| P3M16F | M16 Instrument Air Compr. - Bid tab Client appr. |  | 15d | 2009-11-09 A | 2009-11-30 A | E3M1630 | 100% |  |  |  | P3M16F | P3M16F | 860 | 00 |  | 200 | P | P | M | PM12 | LUZ2 | E | PMT | 200 | 400 |  | PMT | 0 | M16 | 2KB4660 |  |
| P3M12D2 | M12 Rotary Feeder - PO issued (Equipment) | milestone | 0d | 2009-12-21 A | 2009-12-21 A | P3M12D1 FF+235d | 100% |  | 155,802 | 155,802 | P3M12D2 | P3M12D2 | 860 | 00 |  | 200 | P | P | M | PM93 | LUZ2 | P | LND | 200 | 400 |  | LND | 0 | M12 | 2DC8940 |  |
| P3M12L | M12 Rotary Feeder - Lead Time/Fabrication |  | 329d | 2009-12-22 A | 2010-11-19 A | P3M12D1, P3M12D2 | 100% | TB26 - 2 - Manuf and Delivy |  |  | P3M12L | P3M12L | 860 | 00 |  | 200 | P | P | M | PM96 | LUZ2 | E | LND | 200 | 400 | DEL | LND | 0 | M12 | 2DC8940 |  |
| P3M10D2 | M10 Catalyst Waste Pumps - PO issued (Equip.) | milestone | 0d | 2010-01-15 A | 2010-01-15 A | HPM30 FF, P3M10D1, P3M10F FF, E3M1030 FF, P3M10C FF | 100% |  | 10,819.6 | 10,819.6 | P3M10D2 | P3M10D2 | 860 | 00 |  | 200 | P | P | M | PM23 | LUZ2 | P | LND | 200 | 400 |  | LND | 1 | M10 | 2PA6690 |  |
| P3M10L | M10 Catalyst Waste Pumps - Lead Time/Fabrication |  | 318d | 2010-01-16 A | 2010-11-30 A | P3M10D2 | 100% | TB26 - 2 - Manuf and Delivy |  |  | P3M10L | P3M10L | 860 | 00 |  | 200 | P | P | M | PM26 | LUZ2 | E | LND | 200 | 400 | DEL | LND | 1 | M10 | 2PA6690 |  |
| HPMM10 | Catalyst W.Pumps(M10) PO/Fabr./Transport to Site | level of effort | 307d | 2010-01-18 A | 2011-03-31 A | P3M10L SS | 100% |  |  |  | HPMM10 | HPMM10 | 867 | 00 |  | 200 | E | P | M | PM93 | LUZ2 | E | LND | 200 | 400 | DFA | LND | L2 |  |  |  |
| P3M07D2 | M07 Catalyst Feed Pumps- PO issued (Equipment) | milestone | 0d | 2010-01-25 A | 2010-01-25 A | P3M07D1 FF | 100% |  | 34,950.6 | 34,950.6 | P3M07D2 | P3M07D2 | 860 | 00 |  | 200 | P | P | M | PM23 | LUZ2 | P | LND | 200 | 400 |  | LND | 0 | M07 | 2PA6670 |  |
| HPMM08 | Teal/DonorPumps (M08) PO/Fabr./Transport to Site | level of effort | 299d | 2010-01-28 A | 2011-03-31 A | P3M08L SS | 100% |  |  |  | HPMM08 | HPMM08 | 867 | 00 |  | 200 | E | P | M | PM93 | LUZ2 | E | LND | 200 | 400 | DFA | LND | L2 |  |  |  |
| P3M08L | M08 Teal/Donor Feed Pump - Lead Time/Fabrication |  | 306d | 2010-01-28 A | 2010-11-30 A | P3M08D2 | 100% | TB26 - 2 - Manuf and Delivy |  |  | P3M08L | P3M08L | 860 | 00 |  | 200 | P | P | M | PM26 | LUZ2 | E | LND | 200 | 400 | DEL | LND | 1 | M08 | 2PA6690 |  |
| P3M08D2 | M08 Teal/Donor Feed Pumps - PO issued (Equip.) | milestone | 0d | 2010-01-28 A | 2010-01-28 A | HPM30 FF, P3M08C FF, P3M08F FF, P3M08D1, E3M0830 FF | 100% |  | 20,590.6 | 20,590.6 | P3M08D2 | P3M08D2 | 860 | 00 |  | 200 | P | P | M | PM23 | LUZ2 | P | LND | 200 | 400 |  | LND | 1 | M08 | 2PA6690 |  |
| P3M14C | M14 Submers. Pumps - Eval./Negotiation |  | 170d | 2010-02-01 A | 2010-09-30 A | P3M14B, E3M1420 FF | 100% |  |  |  | P3M14C | P3M14C | 860 | 00 |  | 200 | P | P | M | PM92 | LUZ2 | E | LND | 200 | 400 |  | LND | 0 | M14 | 2PA6900 |  |
| P3M15F | M15 Conds./BoosterP. - Bid tab Client appr. |  | 41d | 2010-02-04 A | 2010-04-01 A | E3M1530 | 100% |  |  |  | P3M15F | P3M15F | 860 | 00 |  | 200 | P | P | M | PM22 | LUZ2 | E | PMT | 200 | 400 |  | PMT | 0 | M15 | 2PA6720 |  |
| P3M16D | M16 Instrument Air Compr.- PO issued | milestone | 0d | 2010-02-22 A | 2010-02-22 A | HPM30 FF, P3M16C FF, P3M16F FF | 100% |  | 66,115 | 66,115 | P3M16D | P3M16D | 860 | 00 |  | 200 | P | P | M | PM13 | LUZ2 | E | LND | 200 | 400 |  | LND | 0 | M16 | 2KB4660 |  |
| HPM30 | Rotating Eqpt - Remaining Equipment PO's | level of effort | 153d | 2010-02-23 A | 2010-09-29 A | P3M01AL SS, P3M16L SS | 100% |  |  |  | HPM30 | HPM30 | 869 | 00 |  | 200 | E | P | M | PM93 | LUZ2 | P | LND | 200 | 400 | DFA | LND | L2 |  |  |  |
| HPMM16 | Instr.Compr. (M16) PO/Fabr./Transport to Site | level of effort | 360d | 2010-02-23 A | 2011-07-20 A | P3M16L SS, P3M01AL SS | 100% |  |  |  | HPMM16 | HPMM16 | 867 | 00 |  | 200 | E | P | M | PM93 | LUZ2 | E | LND | 200 | 400 | DFA | LND | L2 |  |  |  |
| P3M16L | M16 Instrument Air Compr - Lead Time/Fabrication |  | 357d | 2010-02-23 A | 2011-02-18 A | P3M16D | 100% | TB26 - 2 - Manuf and Delivy |  |  | P3M16L | P3M16L | 860 | 00 |  | 200 | P | P | M | PM16 | LUZ2 | E | LND | 200 | 400 | DEL | LND | 0 | M16 | 2KB4660 |  |
| P3M15D | M15 Conds./BoosterP. - PO issued | milestone | 0d | 2010-04-14 A | 2010-04-14 A | P3M15F, HPM30 FF, P3M15C | 100% |  | 20,400 | 20,400 | P3M15D | P3M15D | 860 | 00 |  | 200 | P | P | M | PM93 | LUZ2 | E | LND | 200 | 400 |  | LND | 0 | M15 | 2PA6720 |  |
| HPMM15 | Conds./BoosterP.(M15) PO/Fabr./Transport to Site | level of effort | 201d | 2010-04-15 A | 2011-01-27 A | P3M15L SS | 100% |  |  |  | HPMM15 | HPMM15 | 867 | 00 |  | 200 | E | P | M | PM93 | LUZ2 | E | LND | 200 | 400 | DFA | LND | L2 |  |  |  |
| P3M15L | M15 Conds./BoosterP. - Lead Time/Fabrication |  | 229d | 2010-04-15 A | 2010-11-30 A | P3M15D | 100% | TB26 - 2 - Manuf and Delivy |  |  | P3M15L | P3M15L | 860 | 00 |  | 200 | P | P | M | PM96 | LUZ2 | E | LND | 200 | 400 | DEL | LND | 0 | M15 | 2PA6720 |  |
| P3M01AA | M01A PCW Cooler - Prepare/Issue RFQ |  | 4d | 2010-04-30 A | 2010-05-05 A | E3M01A10 | 100% |  |  |  | P3M01AA | P3M01AA | 860 | 00 |  | 200 | P | P | M | PM11 | LUZ2 | E | LND | 200 | 400 | DEV | LND | 0 | M01A | 2KB9850 |  |
| P3M01AB | M01A PCW Cooler - RFQ issued | milestone | 0d | 2010-05-06 A | 2010-05-06 A | P3M01AA FF | 100% |  |  |  | P3M01AB | P3M01AB | 860 | 00 |  | 200 | P | P | M | PM11 | LUZ2 | E | LND | 200 | 400 | DEV | LND | 0 | M01A | 2KB9850 |  |
| P3M01AC | M01A PCW Cooler - Eval./Negotiation |  | 29d | 2010-06-07 A | 2010-07-15 A | E3M01A20 FF, P3M01AB | 100% |  |  |  | P3M01AC | P3M01AC | 860 | 00 |  | 200 | P | P | M | PM12 | LUZ2 | E | LND | 200 | 400 |  | LND | 0 | M01A | 2KB9850 |  |
| P3M02G | M02 Gost R Certificate to russ. customs | milestone | 0d | 2010-06-11 A | 2010-06-11 A | P3M02N FF-90d | 100% | TB26 - 2 - Manuf and Delivy |  |  | P3M02G | P3M02G | 860 | 00 |  | 200 | P | P | M | PM18 | LUZ2 | E | LND | 200 | 400 |  | LND | 0 | M02 | 2DC8490 |  |
| P3M01AD | M01A PCW Cooler - PO issued | milestone | 0d | 2010-07-15 A | 2010-07-15 A | P3M16F FF, P3M01AC FF, HPM30 FF | 100% |  |  |  | P3M01AD | P3M01AD | 860 | 00 |  | 200 | P | P | M | PM13 | LUZ2 | E | LND | 200 | 400 |  | LND | 0 | M01A | 2KB9850 |  |
| P3M01AL | M01A PCW Cooler - Lead Time/Fabrication |  | 179d | 2010-07-17 A | 2011-01-14 A | P3M01AD | 100% | TB26 - 2 - Manuf and Delivy |  |  | P3M01AL | P3M01AL | 860 | 00 |  | 200 | P | P | M | PM16 | LUZ2 | E | LND | 200 | 400 | DEL | LND | 0 | M01A | 2KB9850 |  |
| P3M09D | M09 Unloading Pumps - PO issued | milestone | 0d | 2010-07-27 A | 2010-07-27 A | HPM30 FF, P3M09F FF, IMS-P-000060 FF, P3M09C FF | 100% |  | 6,000 | 6,000 | P3M09D | P3M09D | 860 | 00 |  | 200 | P | P | M | PM23 | LUZ2 | E | LND | 200 | 400 |  | LND | 1 | M09 | 2PA6680 |  |
| HPMM09 | Unloading Pumps (M09) PO/Fabr./Transport to Site | level of effort | 218d | 2010-07-28 A | 2011-06-01 A | P3M09L SS | 100% |  |  |  | HPMM09 | HPMM09 | 867 | 00 |  | 200 | E | P | M | PM93 | LUZ2 | E | LND | 200 | 400 | DFA | LND | L2 |  |  |  |
| P3M09L | M09 Unloading Pumps - Lead Time/Fabrication |  | 85d | 2010-07-28 A | 2010-10-20 A | P3M09D | 100% | TB26 - 2 - Manuf and Delivy |  |  | P3M09L | P3M09L | 860 | 00 |  | 200 | P | P | M | PM26 | LUZ2 | E | LND | 200 | 400 | DEL | LND | 1 | M09 | 2PA6680 |  |
| P3M09G | M09 Gost R Certificate to russ. customs | milestone | 0d | 2010-08-25 A | 2010-08-25 A | P3M09N FF-90d | 100% | TB26 - 2 - Manuf and Delivy |  |  | P3M09G | P3M09G | 860 | 00 |  | 200 | P | P | M | PM28 | LUZ2 | E | LND | 200 | 400 |  | LND | 0 | M09 | 2PA6680 |  |
| P3M03G | M03 Gost R Certificate to russ. customs | milestone | 0d | 2010-09-03 A | 2010-09-03 A | P3M03N FF-90d | 100% | TB26 - 2 - Manuf and Delivy |  |  | P3M03G | P3M03G | 860 | 00 |  | 200 | P | P | M | PM18 | LUZ2 | E | LND | 200 | 400 |  | LND | 0 | M03 | 2DC8460 |  |
| P3M12G | M12 Gost R Certificate to russ. customs | milestone | 0d | 2010-09-13 A | 2010-09-13 A | P3M12N FF-90d | 100% | TB26 - 2 - Manuf and Delivy |  |  | P3M12G | P3M12G | 860 | 00 |  | 200 | P | P | M | PM98 | LUZ2 | E | LND | 200 | 400 |  | LND | 0 | M12 | 2DC8940 |  |
| P3M14F | M14 Submers. Pumps - Bid tab Client appr. |  | 5d | 2010-09-20 A | 2010-09-24 A | E3M1430 | 100% |  |  |  | P3M14F | P3M14F | 860 | 00 |  | 200 | P | P | M | PM22 | LUZ2 | E | PMT | 200 | 400 |  | PMT | 0 | M14 | 2PA6900 |  |
| P3M06G | M06 Gost R Certificate to russ. customs | milestone | 0d | 2010-09-27 A | 2010-09-27 A | P3M06N FF-90d | 100% | TB26 - 2 - Manuf and Delivy |  |  | P3M06G | P3M06G | 860 | 00 |  | 200 | P | P | M | PM28 | LUZ2 | E | LND | 200 | 400 |  | LND | 0 | M06 | 2PA6540 |  |
| P3M15G | M15 Gost R Certificate to russ. customs | milestone | 0d | 2010-09-27 A | 2010-09-27 A | P3M15N FF-90d | 100% | TB26 - 2 - Manuf and Delivy |  |  | P3M15G | P3M15G | 860 | 00 |  | 200 | P | P | M | PM98 | LUZ2 | E | LND | 200 | 400 |  | LND | 0 | M15 | 2PA6720 |  |

Notes:
- HPMM06: UDF_Actictity Name (Russia): Насосы теплой воды (M06), заказ на поставку/изготовление/транспортировка на площадку
- HPMM04: UDF_Actictity Name (Russia): Компрессор газовых сдувок (M04), заказ на поставку/изготовление/транспортировка на площадку
- P3M06D2: Expenses: 900A 37796
- P3M11D: Expenses: 900A 228180
- P3M05D: Expenses: 900A 232359
- HPMM05: UDF_Actictity Name (Russia): Насосы охлаждающей воды реактора (M05), заказ на поставку/изготовление/транспортировка на площадку
- HPMM07: UDF_Actictity Name (Russia): Насосы подачи катализатора (M07), заказ на поставку/изготовление/транспортировка на площадку
- HPM20: UDF_Actictity Name (Russia): Вращающееся оборудование - Оставшиеся заказы на проектирование
- P3M14B: Expenses: 900A 2450
- P3M15B: Expenses: 900A 5100
- P3M16B: Expenses: 900A 16528.8
- P3M12D2: Expenses: 900A 155802
- P3M10D2: Expenses: 900A 10819.6
- HPMM10: UDF_Actictity Name (Russia): Насосы отработанного катализатора (M10), заказ на поставку/изготовление/транспортировка на площадку
- P3M07D2: Expenses: 900A 34950.6
- HPMM08: UDF_Actictity Name (Russia): Насосы ТЭА/донора (M08), заказ на поставку/изготовление/транспортировка на площадку
- P3M08D2: Expenses: 900A 20590.6
- P3M16D: Expenses: 900A 66115
- HPM30: UDF_Actictity Name (Russia): Вращающееся оборудование - Оставшиеся заказы на поставку
- HPMM16: UDF_Actictity Name (Russia): Компрессор воздуха КИП (M16), заказ на поставку/изготовление/транспортировка на площадку
- P3M15D: Expenses: 900A 20400
- HPMM15: UDF_Actictity Name (Russia): Насос конденсата/бустерный насос (M15), заказ на поставку/изготовление/транспортировка на площадку
- P3M09D: Expenses: 900A 6000
- HPMM09: UDF_Actictity Name (Russia): Насосы разгрузки (M09), заказ на поставку/изготовление/транспортировка на площадку

| ID | Activity | Type | Duration | Start | Finish | Predecessors | Complete | Remaining | Total float | Free float | Constraint | Expected finish | Calendar | Cost | Actual cost | UDF_SAVE ACTID | UDF_SAVE ACT ID | Department | Type of Work | Constr. Area | Inquiry/Order No | PMT-Area | PMT-Schedule Org | PMT-Discipline | PMT-Phase | PMT-Respons. | Zeigen/n. Zeigen | WBS Phase | WBS Discipline | WBS Type of Work | WBS Objects | IMS | UPT | PMT-Doc. Type | Pro Unit/DocCode | UDF_CHECK BASELINE |
| --- | --- | --- | --- | --- | --- | --- | --- | --- | --- | --- | --- | --- | --- | --- | --- | --- | --- | --- | --- | --- | --- | --- | --- | --- | --- | --- | --- | --- | --- | --- | --- | --- | --- | --- | --- | --- |
| P3M14D | M14 Submers. Pumps - PO issued | milestone | 0d | 2010-09-30 A | 2010-09-30 A | IMS-P-000060 FF, HPM30 FF, P3M14F FF, P3M14C FF | 100% |  |  |  |  |  |  | 9,800 | 9,800 | P3M14D | P3M14D | 860 | M14 | 00 | 2PA6900 | 200 | 200 | 400 | P | LND | 0 | P | M | PM93 | LUZ2 | E | LND |  |  |  |
| HPMM14 | Submers. Pumps (M14) PO/Fabr./Transport to Site | level of effort | 269d | 2010-10-01 A | 2011-10-18 | P3M14L SS |  | 33d | 84d | 0d |  |  |  |  |  | HPMM14 | HPMM14 | 867 |  | 00 |  | 200 | 200 | 400 | E | LND | L2 | P | M | PM93 | LUZ2 | E | LND | DFA |  |  |
| P3M10G | M10 Gost R Certificate to russ. customs | milestone | 0d | 2010-10-01 A | 2010-10-01 A | P3M10N FF-90d | 100% |  |  |  |  |  | TB26 - 2 - Manuf and Delivy |  |  | P3M10G | P3M10G | 860 | M10 | 00 | 2PA6690 | 200 | 200 | 400 | P | LND | 0 | P | M | PM28 | LUZ2 | E | LND |  |  |  |
| P3M14L | M14 Submers. Pumps - Lead Time/Fabrication |  | 214d | 2010-10-01 A | 2011-05-06 A | P3M14D | 100% |  |  |  |  |  | TB26 - 2 - Manuf and Delivy |  |  | P3M14L | P3M14L | 860 | M14 | 00 | 2PA6900 | 200 | 200 | 400 | P | LND | 0 | P | M | PM96 | LUZ2 | E | LND | DEL |  |  |
| P3M08G | M08 Gost R Certificate to russ. customs | milestone | 0d | 2010-10-02 A | 2010-10-02 A | P3M08N FF-90d | 100% |  |  |  |  |  | TB26 - 2 - Manuf and Delivy |  |  | P3M08G | P3M08G | 860 | M08 | 00 | 2PA6690 | 200 | 200 | 400 | P | LND | 0 | P | M | PM28 | LUZ2 | E | LND |  |  |  |
| P3M06X | M06 R. Tepid Pumps - Final Inspection |  | 2d | 2010-10-04 A | 2010-10-05 A | E3M0660 FF+10d, P3M06D2, P3M06L FF-20d | 100% |  |  |  |  |  | TB26 - 2 - Manuf and Delivy | 56,694 | 56,694 | P3M06X | P3M06X | 860 | M06 | 00 | 2PA6540 | 200 | 200 | 400 | P | LND | C2 | P | M | PM27 | LUZ2 | E | LND |  | DC |  |
| P3M15X | M15 Conds./BoosterP. - Final Inspection | milestone | 0d | 2010-10-04 A | 2010-10-04 A | P3M15L FF-5d, E3M1550 FF, P3M15D, E3M1560 FF | 100% |  |  |  |  |  | TB26 - 2 - Manuf and Delivy | 30,600 | 30,600 | P3M15X | P3M15X | 860 | M15 | 00 | 2PA6720 | 200 | 200 | 400 | P | LND | 0 | P | M | PM97 | LUZ2 | E | LND |  |  |  |
| P3M12X | M12 Rotary Feeder - Final Inspection | milestone | 0d | 2010-10-08 A | 2010-10-08 A | E3M1250 FF, P3M12D2 FF, P3M12L FF-12d, E3M1260 FF | 100% |  |  |  |  |  | TB26 - 2 - Manuf and Delivy | 233,703 | 233,703 | P3M12X | P3M12X | 860 | M12 | 00 | 2DC8940 | 200 | 200 | 400 | P | LND | 0 | P | M | PM97 | LUZ2 | E | LND |  |  |  |
| P3M07G | M07 Gost R Certificate to russ. customs | milestone | 0d | 2010-10-13 A | 2010-10-13 A | P3M07N FF-90d | 100% |  |  |  |  |  | TB26 - 2 - Manuf and Delivy |  |  | P3M07G | P3M07G | 860 | M07 | 00 | 2PA6670 | 200 | 200 | 400 | P | LND | 0 | P | M | PM28 | LUZ2 | E | LND |  |  |  |
| P3M09X | M09 Unloading Pumps - Final Inspection | milestone | 0d | 2010-10-15 A | 2010-10-15 A | P3M09L FF-10d, P3M09D | 100% |  |  |  |  |  | TB26 - 2 - Manuf and Delivy | 9,000 | 9,000 | P3M09X | P3M09X | 860 | M09 | 00 | 2PA6680 | 200 | 200 | 400 | P | LND | 1 | P | M | PM27 | LUZ2 | E | LND |  |  |  |
| P3M05G | M05 Gost R Certificate to russ. customs | milestone | 0d | 2010-10-17 A | 2010-10-17 A | P3M05N FF-90d | 100% |  |  |  |  |  | TB26 - 2 - Manuf and Delivy |  |  | P3M05G | P3M05G | 860 | M05 | 00 | 2PA6550 | 200 | 200 | 400 | P | LND | 0 | P | M | PM28 | LUZ2 | E | LND |  |  |  |
| P3M09M | M09 Unloading Pumps - Goods deliv. FOB | milestone | 0d | 2010-10-20 A | 2010-10-20 A | P3M09X FF, P3M09L FF | 100% |  |  |  |  |  | TB26 - 2 - Manuf and Delivy | 4,500 | 4,500 | P3M09M | P3M09M | 860 | M09 | 00 | 2PA6680 | 200 | 200 | 400 | P | LND | 1 | P | M | PM28 | LUZ2 | E | LND |  |  |  |
| P3M08X | M08 Teal/Donor Feed Pumps - Final Inspection | milestone | 0d | 2010-10-27 A | 2010-10-27 A | P3M08L FF-10d, E3M0850 FF, E3M0860 FF | 100% |  |  |  |  |  | TB26 - 2 - Manuf and Delivy | 30,885.9 | 30,885.9 | P3M08X | P3M08X | 860 | M08 | 00 | 2PA6690 | 200 | 200 | 400 | P | LND | 1 | P | M | PM27 | LUZ2 | E | LND |  |  |  |
| P3M10X | M10 Catalyst Waste Pumps - Final Inspection | milestone | 0d | 2010-10-27 A | 2010-10-27 A | E3M1060 FF, P3M10L FF-10d, E3M1050 FF | 100% |  |  |  |  |  | TB26 - 2 - Manuf and Delivy | 16,229.4 | 16,229.4 | P3M10X | P3M10X | 860 | M10 | 00 | 2PA6690 | 200 | 200 | 400 | P | LND | 1 | P | M | PM27 | LUZ2 | E | LND |  |  |  |
| P3M11T1 | M11 RA Gear Motor-Transport ABB(ITA)-Lufkin(FRA) |  | 5d | 2010-10-29 A | 2010-11-02 A | P3E04N FF | 100% |  |  |  |  |  | TB26 - 2 - Manuf and Delivy |  |  | P3M11T1 | P3M11T1 | 860 | M11 | 00 | 2KB4290 | 200 | 200 | 400 | P | LND | C2 | P | M | PM97 | LUZ2 | E | LND |  | DC |  |
| P3M17A | M17 Chiller Unit - Prepare/Issue RFQ |  | 3d | 2010-11-03 A | 2010-11-05 A | E3M1710 | 100% |  |  |  |  |  |  |  |  | P3M17A | P3M17A | 860 | M17 | 00 | 2KB9890 | 200 | 200 | 400 | P | LND | 0 | P | M | PM11 | LUZ2 | E | LND | DEV |  |  |
| P3M17B | M17 Chiller Unit - RFQ issued | milestone | 0d | 2010-11-05 A | 2010-11-05 A | P3M17A FF | 100% |  |  |  |  |  |  |  |  | P3M17B | P3M17B | 860 | M17 | 00 | 2KB9890 | 200 | 200 | 400 | P | LND | 0 | P | M | PM11 | LUZ2 | E | LND | DEV |  |  |
| P3M01X | M01 Extruder Pck. - Final Inspection |  | 30d | 2010-11-18 A | 2010-12-17 A | P3M01L1, P3M01L FF-15d, F7280 FF+10d, P3M01D, E3M0160 FF+10d, E3M0180 | 100% |  |  |  |  |  | TB26 - 2 - Manuf and Delivy |  |  | P3M01X | P3M01X | 860 | M01 | 00 | 2DC8480 | 200 | 200 | 400 | P | LND | C2 | P | M | PM37 | LUZ2 | E | LND |  | DC |  |
| P3M05X | M05 R. Quench Pumps - Final Inspection |  | 3d | 2010-11-21 A | 2010-11-23 A | E3M0560 FF+10d, P3M05L FF-8d | 100% |  |  |  |  |  | TB26 - 2 - Manuf and Delivy | 348,538.2 | 348,538.2 | P3M05X | P3M05X | 860 | M05 | 00 | 2PA6550 | 200 | 200 | 400 | P | LND | C2 | P | M | PM27 | LUZ2 | E | LND |  | DC |  |
| P3M01X1 | M01 Extruder Pck. - Final Inspection 1st Part |  | 5d | 2010-11-23 A | 2010-11-27 A | P3M01X SF+10d | 100% |  |  |  |  |  | TB26 - 2 - Manuf and Delivy | 5,103,060 | 5,103,060 | P3M01X1 | P3M01X1 | 860 | M01 | 00 | 2DC8480 | 200 | 200 | 400 | P | LND | C2 | P | M | PM37 | LUZ2 | E | LND |  | DC |  |
| P3M11T2 | M11 RA Gear Unit - Integration Works (Motors) |  | 10d | 2010-11-23 A | 2010-12-02 A | P3M11T1 FS+20d | 100% |  |  |  |  |  | TB26 - 2 - Manuf and Delivy |  |  | P3M11T2 | P3M11T2 | 860 | M11 | 00 | 2KB4290 | 200 | 200 | 400 | P | LND | C2 | P | M | PM97 | LUZ2 | E | LND |  | DC |  |
| P3M12M | M12 Rotary Feeder - Goods deliv. FOB | milestone | 0d | 2010-11-24 A | 2010-11-24 A | P3M12X FF, P3M12L FF+5d | 100% |  |  |  |  |  | TB26 - 2 - Manuf and Delivy | 116,851.5 | 116,851.5 | P3M12M | P3M12M | 860 | M12 | 00 | 2DC8940 | 200 | 200 | 400 | P | LND | 0 | P | M | PM98 | LUZ2 | E | LND |  |  |  |
| P3M05M | M05 R. Quench Pumps - Goods delivered FOB | milestone | 0d | 2010-11-30 A | 2010-11-30 A | P3M05L FF, E3M0570 | 100% |  |  |  |  |  | TB26 - 2 - Manuf and Delivy | 174,269.1 | 174,269.1 | P3M05M | P3M05M | 860 | M05 | 00 | 2PA6550 | 200 | 200 | 400 | P | LND | C2 | P | M | PM28 | LUZ2 | E | LND |  | DC |  |
| P3M06M | M06 R. Tepid Pumps - Goods delivered FOB | milestone | 0d | 2010-11-30 A | 2010-11-30 A | P3M06L FF, E3M0670 | 100% |  |  |  |  |  | TB26 - 2 - Manuf and Delivy | 28,347 | 28,347 | P3M06M | P3M06M | 860 | M06 | 00 | 2PA6540 | 200 | 200 | 400 | P | LND | C2 | P | M | PM28 | LUZ2 | E | LND |  | DC |  |
| P3M08M | M08 Teal/Donor Feed Pumps - Goods deliv. FOB | milestone | 0d | 2010-11-30 A | 2010-11-30 A | P3M08L FF, P3M08X FF | 100% |  |  |  |  |  | TB26 - 2 - Manuf and Delivy | 15,442.95 | 15,442.95 | P3M08M | P3M08M | 860 | M08 | 00 | 2PA6690 | 200 | 200 | 400 | P | LND | 1 | P | M | PM28 | LUZ2 | E | LND |  |  |  |
| P3M10M | M10 Catalyst Waste Pumps - Goods deliv. FOB | milestone | 0d | 2010-11-30 A | 2010-11-30 A | P3M10L FF, P3M10X FF | 100% |  |  |  |  |  | TB26 - 2 - Manuf and Delivy | 8,114.7 | 8,114.7 | P3M10M | P3M10M | 860 | M10 | 00 | 2PA6690 | 200 | 200 | 400 | P | LND | 1 | P | M | PM28 | LUZ2 | E | LND |  |  |  |
| P3M15M | M15 Conds./BoosterP. - Goods deliv. FOB | milestone | 0d | 2010-11-30 A | 2010-11-30 A | P3M15L FF, P3M15X FF | 100% |  |  |  |  |  | TB26 - 2 - Manuf and Delivy | 15,300 | 15,300 | P3M15M | P3M15M | 860 | M15 | 00 | 2PA6720 | 200 | 200 | 400 | P | LND | 0 | P | M | PM98 | LUZ2 | E | LND |  |  |  |
| P3M04G | M04 Gost R Certificate to russ. customs | milestone | 0d | 2010-12-05 A | 2010-12-05 A | P3M04N FF-90d | 100% |  |  |  |  |  | TB26 - 2 - Manuf and Delivy |  |  | P3M04G | P3M04G | 860 | M04 | 00 | 2KB4360 | 200 | 200 | 400 | P | LND | 0 | P | M | PM18 | LUZ2 | E | LND |  |  |  |
| P3M01AG | M01A Gost R Certificate to russ. customs | milestone | 0d | 2010-12-08 A | 2010-12-08 A | P3M01AN FF-90d | 100% |  |  |  |  |  | TB26 - 2 - Manuf and Delivy |  |  | P3M01AG | P3M01AG | 860 | M01A | 00 | 2KB9850 | 200 | 200 | 400 | P | LND | 0 | P | M | PM18 | LUZ2 | E | LND |  |  |  |
| P3M16G | M16 Gost R Certificate to russ. customs | milestone | 0d | 2010-12-11 A | 2010-12-11 A | P3M16N FF-90d | 100% |  |  |  |  |  | TB26 - 2 - Manuf and Delivy |  |  | P3M16G | P3M16G | 860 | M16 | 00 | 2KB4660 | 200 | 200 | 400 | P | LND | 0 | P | M | PM18 | LUZ2 | E | LND |  |  |  |
| P3M01G | M01 Gost R Certificate to russ. customs | milestone | 0d | 2010-12-13 A | 2010-12-13 A | P3M01N FF-90d | 100% |  |  |  |  |  | TB26 - 2 - Manuf and Delivy |  |  | P3M01G | P3M01G | 860 | M01 | 00 | 2DC8480 | 200 | 200 | 400 | P | LND | 0 | P | M | PM38 | LUZ2 | E | LND |  |  |  |
| P3M11G | M11 Gost R Certificate to russ. customs | milestone | 0d | 2010-12-15 A | 2010-12-15 A | P3M11N FF-90d | 100% |  |  |  |  |  | TB26 - 2 - Manuf and Delivy |  |  | P3M11G | P3M11G | 860 | M11 | 00 | 2KB4290 | 200 | 200 | 400 | P | LND | 0 | P | M | PM98 | LUZ2 | E | LND |  |  |  |
| P3M05N | M05 R. Quench Pumps - Transport to Site |  | 39d | 2010-12-16 A | 2011-01-26 A | P3M05M FS+15d, P3M05X, P3M05L | 100% |  |  |  |  |  | TB26 - 2 - Manuf and Delivy |  |  | P3M05N | P3M05N | 860 | M05 | 00 | 2PA6550 | 200 | 200 | 400 | P | LND | C2 | P | M | PM28 | LUZ2 | E | LND |  | DC |  |
| P3M06N | M06 R. Tepid Pumps - Transport to Site |  | 39d | 2010-12-16 A | 2011-01-26 A | P3M06X, P3M06M FS+15d, P3M06L | 100% |  |  |  |  |  | TB26 - 2 - Manuf and Delivy |  |  | P3M06N | P3M06N | 860 | M06 | 00 | 2PA6540 | 200 | 200 | 400 | P | LND | C2 | P | M | PM28 | LUZ2 | E | LND |  | DC |  |
| P3M15N | M15 Conds./BoosterP. - Transport to Site |  | 40d | 2010-12-16 A | 2011-01-27 A | P3B100 FF, P3M15M FS+15d | 100% |  |  |  |  |  | TB26 - 2 - Manuf and Delivy |  |  | P3M15N | P3M15N | 860 | M15 | 00 | 2PA6720 | 200 | 200 | 400 | P | LND | 0 | P | M | PM98 | LUZ2 | E | LND |  |  |  |
| P3M01AX | M01A PCW Cooler - Final Inspection | milestone | 0d | 2010-12-20 A | 2010-12-20 A | P3M01AL FF-10d, E3M01A60 FF, E3M01A50 FF, P3M01AD FF | 100% |  |  |  |  |  | TB26 - 2 - Manuf and Delivy |  |  | P3M01AX | P3M01AX | 860 | M01A | 00 | 2KB9850 | 200 | 200 | 400 | P | LND | 0 | P | M | PM17 | LUZ2 | E | LND |  |  |  |
| P3M17C | M17 Chiller Unit - Eval./Negotiation |  | 142d | 2011-01-06 A | 2011-07-22 A | P3M17B, E3M1720 FF | 100% |  |  |  |  |  |  |  |  | P3M17C | P3M17C | 860 | M17 | 00 | 2KB9890 | 200 | 200 | 400 | P | LND | 0 | P | M | PM12 | LUZ2 | E | LND |  |  |  |
| P3M01AM | M01A PCW Cooler - Goods deliv. FOB | milestone | 0d | 2011-01-19 A | 2011-01-19 A | P3M01AL FF+5d, P3M01AX FF | 100% |  |  |  |  |  | TB26 - 2 - Manuf and Delivy |  |  | P3M01AM | P3M01AM | 860 | M01A | 00 | 2KB9850 | 200 | 200 | 400 | P | LND | 0 | P | M | PM18 | LUZ2 | E | LND |  |  |  |
| P3M14G | M14 Gost R Certificate to russ. customs | milestone | 0d | 2011-01-20 A | 2011-01-20 A | P3M14N FF-90d | 100% |  |  |  |  |  | TB26 - 2 - Manuf and Delivy |  |  | P3M14G | P3M14G | 860 | M14 | 00 | 2PA6900 | 200 | 200 | 400 | P | LND | 0 | P | M | PM98 | LUZ2 | E | LND |  |  |  |
| P3M07X | M07 Catalyst Feed Pumps - Final Inspection | milestone | 0d | 2011-01-21 A | 2011-01-21 A | E3M0750 FF, E3M0760 FF, P3M07L FF-11d, P3M07D2 FF+100d | 100% |  |  |  |  |  | TB26 - 2 - Manuf and Delivy | 52,425.9 | 52,425.9 | P3M07X | P3M07X | 860 | M07 | 00 | 2PA6670 | 200 | 200 | 400 | P | LND | 0 | P | M | PM27 | LUZ2 | E | LND |  |  |  |
| P3M16X | M16 Instrument Air Compr. - Final Inspection | milestone | 0d | 2011-01-26 A | 2011-01-26 A | P3M16L FF-6d, E3M1650 FF, P3M16D FF, E3M1660 FF | 100% |  |  |  |  |  | TB26 - 2 - Manuf and Delivy | 99,172.8 | 99,172.8 | P3M16X | P3M16X | 860 | M16 | 00 | 2KB4660 | 200 | 200 | 400 | P | LND | 0 | P | M | PM17 | LUZ2 | E | LND |  |  |  |
| P3M11X | M11 RA Gear Unit - Final Inspection |  | 10d | 2011-02-06 A | 2011-02-15 A | P3M11L FF-10d, P3M11T2, E3M1175, E3M1160 FF+10d | 100% |  |  |  |  |  | TB26 - 2 - Manuf and Delivy | 342,270 | 342,270 | P3M11X | P3M11X | 860 | M11 | 00 | 2KB4290 | 200 | 200 | 400 | P | LND | C2 | P | M | PM97 | LUZ2 | E | LND |  | DC |  |
| P3M07M | M07 Catalyst Feed Pumps - Goods deliv. FOB | milestone | 0d | 2011-02-15 A | 2011-02-15 A | P3M07X FF, P3M07L FF+15d | 100% |  |  |  |  |  | TB26 - 2 - Manuf and Delivy | 26,212.95 | 26,212.95 | P3M07M | P3M07M | 860 | M07 | 00 | 2PA6670 | 200 | 200 | 400 | P | LND | 0 | P | M | PM28 | LUZ2 | E | LND |  |  |  |
| P3M16M | M16 Instrument Air Compr. - Goods deliv. FOB | milestone | 0d | 2011-02-28 A | 2011-02-28 A | P3M16L FF+10d, P3M16X FF | 100% |  |  |  |  |  | TB26 - 2 - Manuf and Delivy | 49,586.4 | 49,586.4 | P3M16M | P3M16M | 860 | M16 | 00 | 2KB4660 | 200 | 200 | 400 | P | LND | 0 | P | M | PM18 | LUZ2 | E | LND |  |  |  |
| P3M01M2 | M01 Extruder Pck. - Motor Pck. delivered FOB Europe | milestone | 0d | 2011-03-04 A | 2011-03-04 A | P3M01D | 100% |  |  |  | finish on or after 2011-03-04 |  | TB26 - 2 - Manuf and Delivy |  |  | P3M01M2 | P3M01M2 | 860 | M01 | 00 | 2DC8480 | 200 | 200 | 400 | P | LND | C2 | P | M | PM38 | LUZ2 | E | LND |  | DC |  |
| P3M01N2 | M01 Extruder - Motor Pck. Transport to Site |  | 35d | 2011-03-05 A | 2011-04-08 A | P3M01M2 | 100% |  |  |  |  |  | TB26 - 2 - Manuf and Delivy |  |  | P3M01N2 | P3M01N2 | 860 | M01 | 00 | 2DC8480 | 200 | 200 | 400 | P | LND | C2 | P | M | PM38 | LUZ2 | E | LND |  | DC |  |
| P3M08N | M08 Teal/Donor Feed Pumps - Transport to Site (collection of div. packages) |  | 25d | 2011-03-07 A | 2011-03-31 A | P3M08M FS+10d | 100% |  |  |  | start on or after 2011-03-07 |  | TB26 - 2 - Manuf and Delivy |  |  | P3M08N | P3M08N | 860 | M08 | 00 | 2PA6690 | 200 | 200 | 400 | P | LND | 1 | P | M | PM28 | LUZ2 | E | LND |  |  |  |
| P3M10N | M10 Catalyst Waste Pumps - Transport to Site (collection of div. packages) |  | 25d | 2011-03-07 A | 2011-03-31 A | P3M10M FS+10d | 100% |  |  |  | start on 2011-03-07 |  | TB26 - 2 - Manuf and Delivy |  |  | P3M10N | P3M10N | 860 | M10 | 00 | 2PA6690 | 200 | 200 | 400 | P | LND | 1 | P | M | PM28 | LUZ2 | E | LND |  |  |  |
| P3M11N | M11 RA Gear - Transport to Site/Custom Clearance |  | 25d | 2011-03-07 A | 2011-03-31 A | P3M11M FS-1d, P3M11X, P3M11L | 100% |  |  |  |  |  | TB26 - 2 - Manuf and Delivy |  |  | P3M11N | P3M11N | 860 | M11 | 00 | 2KB4290 | 200 | 200 | 400 | P | LND | C2 | P | M | PM98 | LUZ2 | E | LND |  | DC |  |
| P3M11M | M11 RA Gear Unit - Goods delivered FOB or FCA | milestone | 0d | 2011-03-07 A | 2011-03-07 A | P3M11L FF+10d | 100% |  |  |  |  |  | TB26 - 2 - Manuf and Delivy | 171,135 | 171,135 | P3M11M | P3M11M | 860 | M11 | 00 | 2KB4290 | 200 | 200 | 400 | P | LND | C2 | P | M | PM98 | LUZ2 | E | LND |  | DC |  |
| P3M01AN | M01A PCW Cooler - Transport to Site |  | 16d | 2011-04-20 A | 2011-05-06 A | P3M01AM | 100% |  |  |  | start on or after 2011-04-20 |  | TB26 - 2 - Manuf and Delivy |  |  | P3M01AN | P3M01AN | 860 | M01A | 00 | 2KB9850 | 200 | 200 | 400 | P | LND | 0 | P | M | PM18 | LUZ2 | E | LND |  |  |  |
| P3M09N | M09 Unloading Pumps - Transport to Site (class.decision still open, collection div. packages) |  | 29d | 2011-05-04 A | 2011-06-01 A | P3M09M | 100% |  |  |  | start on 2011-05-04 |  | TB26 - 2 - Manuf and Delivy |  |  | P3M09N | P3M09N | 860 | M09 | 00 | 2PA6680 | 200 | 200 | 400 | P | LND | 1 | P | M | PM28 | LUZ2 | E | LND |  |  |  |
| P3M14X | M14 Submers. Pumps - Final Inspection | milestone | 0d | 2011-05-04 A | 2011-05-04 A | E3M1460 FF, P3M14D, P3M14L FF-3d, E3M1450 FF | 100% |  |  |  |  |  | TB26 - 2 - Manuf and Delivy | 14,700 | 14,700 | P3M14X | P3M14X | 860 | M14 | 00 | 2PA6900 | 200 | 200 | 400 | P | LND | 0 | P | M | PM97 | LUZ2 | E | LND |  |  |  |
| P3M14M | M14 Submers. Pumps - Goods deliv. FOB/FCA | milestone | 0d | 2011-05-21 A | 2011-05-21 A | P3M14X FF, P3M14L FF+15d | 100% |  |  |  |  |  | TB26 - 2 - Manuf and Delivy | 7,350 | 7,350 | P3M14M | P3M14M | 860 | M14 | 00 | 2PA6900 | 200 | 200 | 400 | P | LND | 0 | P | M | PM98 | LUZ2 | E | LND |  |  | x |
| P3M17F | M17 Chiller Unit - Bid tab Client appr. |  | 39d | 2011-05-23 A | 2011-07-14 A | E3M1730 | 100% |  |  |  |  |  |  |  |  | P3M17F | P3M17F | 860 | M17 | 00 | 2KB9890 | 200 | 200 | 400 | P | PMT | 0 | P | M | PM12 | LUZ2 | E | PMT |  |  | x |
| P3M07N | M07 Catalyst Feed Pumps - Transport to Site |  | 26d | 2011-05-30 A | 2011-06-24 A | P3M07M | 100% |  |  |  |  |  | TB26 - 2 - Manuf and Delivy |  |  | P3M07N | P3M07N | 860 | M07 | 00 | 2PA6670 | 200 | 200 | 400 | P | LND | 0 | P | M | PM28 | LUZ2 | E | LND |  |  |  |
| P3M12N | M12 Rotary Feeder - Transport to Site (collection of div. packages) |  | 23d | 2011-05-30 A | 2011-06-21 A | P3M12M | 100% |  |  |  |  |  | TB26 - 2 - Manuf and Delivy |  |  | P3M12N | P3M12N | 860 | M12 | 00 | 2DC8940 | 200 | 200 | 400 | P | LND | 0 | P | M | PM98 | LUZ2 | E | LND |  |  |  |
| P3M16N | M16 Instrument Air Compr. - Transport to Site |  | 21d | 2011-06-30 A | 2011-07-20 A | P3M16M FS+10d | 100% |  |  |  | start on 2011-06-30 |  | TB26 - 2 - Manuf and Delivy |  |  | P3M16N | P3M16N | 860 | M16 | 00 | 2KB4660 | 200 | 200 | 400 | P | LND | 0 | P | M | PM18 | LUZ2 | E | LND |  |  |  |
| P3M17D | M17 Chiller Unit - PO issued | milestone | 0d | 2011-07-22 A | 2011-07-22 A | P3M17C FF, P3M17F FF, HPM30 FF | 100% |  |  |  |  |  |  |  |  | P3M17D | P3M17D | 860 | M17 | 00 | 2KB9890 | 200 | 200 | 400 | P | LND | 0 | P | M | PM13 | LUZ2 | E | LND |  |  |  |
| P3M17L | M17 Chiller Unit - Lead Time/Fabrication |  | 131d | 2011-07-23 A | 2011-11-30 | P3M17D |  | 91d | 214d | 0d |  | 2011-11-30 | TB26 - 2 - Manuf and Delivy |  |  | P3M17L | P3M17L | 860 | M17 | 00 | 2KB9890 | 200 | 200 | 400 | P | LND | 0 | P | M | PM16 | LUZ2 | E | LND | DEL |  |  |
| P3M14N | M14 Submers. Pumps - Transport to Site |  | 30d | 2011-09-19 | 2011-10-18 | P3M14M FS+20d, P3B100 FF |  |  | -9d | 0d | start on 2011-09-19 |  | TB26 - 2 - Manuf and Delivy |  |  | P3M14N | P3M14N | 860 | M14 | 00 | 2PA6900 | 200 | 200 | 400 | P | LND | 0 | P | M | PM98 | LUZ2 | E | LND |  |  |  |
| P3M17G | M17 Gost R Certificate to russ. customs | milestone | 0d | 2011-10-22 | 2011-10-22 | P3M17N FF-90d |  |  | 304d | 90d |  |  | TB26 - 2 - Manuf and Delivy |  |  | P3M17G | P3M17G | 860 | M17 | 00 | 2KB9890 | 200 | 200 | 400 | P | LND | 0 | P | M | PM18 | LUZ2 | E | LND |  |  |  |
| P3M17X | M17 Chiller Unit - Final Inspection | milestone | 0d | 2011-11-21 | 2011-11-21 | P3M17L FF-10d, E3M1750 FF, P3M17D FF, E3M1760 FF |  |  | 229d | 15d |  |  | TB26 - 2 - Manuf and Delivy |  |  | P3M17X | P3M17X | 860 | M17 | 00 | 2KB9890 | 200 | 200 | 400 | P | LND | 0 | P | M | PM17 | LUZ2 | E | LND |  |  |  |
| P3M17M | M17 Chiller Unit - Goods deliv. FOB | milestone | 0d | 2011-12-05 | 2011-12-05 | P3M17L FF+5d, P3M17X FF |  |  | 214d | 0d |  |  | TB26 - 2 - Manuf and Delivy |  |  | P3M17M | P3M17M | 860 | M17 | 00 | 2KB9890 | 200 | 200 | 400 | P | LND | 0 | P | M | PM18 | LUZ2 | E | LND |  |  |  |
| P3M17N | M17 Chiller Unit - Transport to Site |  | 45d | 2011-12-06 | 2012-01-22 | P3M17M |  |  | 214d | 0d |  |  | TB26 - 2 - Manuf and Delivy |  |  | P3M17N | P3M17N | 860 | M17 | 00 | 2KB9890 | 200 | 200 | 400 | P | LND | 0 | P | M | PM18 | LUZ2 | E | LND |  |  |  |

Notes:
- P3M14D: Expenses: 900A 9800
- HPMM14: UDF_Actictity Name (Russia): Погружные насосы (M14), заказ на поставку/изготовление/транспортировка на площадку
- P3M06X: Expenses: 900A 56694
- P3M15X: Expenses: 900A 30600
- P3M12X: Expenses: 900A 233703
- P3M09X: Expenses: 900A 9000
- P3M09M: Expenses: 900A 4500
- P3M08X: Expenses: 900A 30885.9
- P3M10X: Expenses: 900A 16229.4
- P3M05X: Expenses: 900A 348538
- P3M01X1: Expenses: 900A 5103060
- P3M12M: Expenses: 900A 116852
- P3M05M: Expenses: 900A 174269
- P3M06M: Expenses: 900A 28347
- P3M08M: Expenses: 900A 15443
- P3M10M: Expenses: 900A 8114.7
- P3M15M: Expenses: 900A 15300
- P3M05N: P3 Activity Log Info: Rail
- P3M06N: P3 Activity Log Info: Rail
- P3M07X: Expenses: 900A 52425.9
- P3M16X: Expenses: 900A 99172.8
- P3M11X: Expenses: 900A 342270
- P3M07M: Expenses: 900A 26213
- P3M16M: Expenses: 900A 49586.4
- P3M01N2: P3 Activity Log Info: Ship (15) / Train (30-50) / cust.clear. (30)
- P3M11N: P3 Activity Log Info: per / Truck
- P3M11M: Expenses: 900A 171135
- P3M01AN: P3 Activity Log Info: Rail/Truck
- P3M14X: Expenses: 900A 14700
- P3M14M: Expenses: 900A 7350
- P3M07N: P3 Activity Log Info: Rail/Truck
- P3M12N: P3 Activity Log Info: per / Truck/Rail
- P3M16N: P3 Activity Log Info: Rail/Truck
- P3M17N: P3 Activity Log Info: Rail/Truck

| ID | WBS | Activity | Type | Duration | Start | Finish | Predecessors | Complete | Remaining | Planned start | Planned finish | Total float | Free float | Expected finish | Calendar | Cost | Actual cost | UDF_SAVE ACTID | UDF_SAVE ACT ID | Department | Constr. Area | PMT-Area | PMT-Schedule Org | PMT-Discipline | PMT-Phase | PMT-Doc. Type | PMT-Respons. | Zeigen/n. Zeigen | WBS Phase | WBS Discipline | WBS Type of Work | WBS Objects | IMS | UPT | Type of Work | Inquiry/Order No |
| --- | --- | --- | --- | --- | --- | --- | --- | --- | --- | --- | --- | --- | --- | --- | --- | --- | --- | --- | --- | --- | --- | --- | --- | --- | --- | --- | --- | --- | --- | --- | --- | --- | --- | --- | --- | --- |
|  | R | **R Piping** |  |  | 2010-02-23 | 2012-01-12 |  |  |  |  |  |  |  |  |  |  |  |  |  |  |  |  |  |  |  |  |  |  |  |  |  |  |  |  |  |  |
| HPRR06B |  | AG CS Pipes (R06B) PO/Fabr./Transport to Site | level of effort | 288d | 2010-02-23 A | 2011-04-11 A | P3R06BL SS | 100% |  |  |  |  |  |  |  |  |  | HPRR06B | HPRR06B | 873 | 00 | 200 | 200 | 400 | E | DFA | LND | L2 | P | R | PR23 | LUZ2 | PI | LND |  |  |
| HPRR06 |  | AG SS Fittings (R06) PO/Fabr./Transport to Site | level of effort | 291d | 2010-02-26 A | 2011-04-19 A | P3R06L SS | 100% |  |  |  |  |  |  |  |  |  | HPRR06 | HPRR06 | 873 | 00 | 200 | 200 | 400 | E | DFA | LND | L2 | P | R | PR23 | LUZ2 | PI | LND |  |  |
| HPRR06C |  | AG SS Pipes (R06C) PO/Fabr./Transport to Site | level of effort | 282d | 2010-02-26 A | 2011-04-06 A | P3R06DL SS, P3R06CL SS | 100% |  |  |  |  |  |  |  |  |  | HPRR06C | HPRR06C | 873 | 00 | 200 | 200 | 400 | E | DFA | LND | L2 | P | R | PR23 | LUZ2 | PI | LND |  |  |
| HPRR04 |  | AG Valves (R04) PO/Fabr./Transport to Site | level of effort | 318d | 2010-03-10 A | 2011-06-07 A | P3R04L SS | 100% |  |  |  |  |  |  |  |  |  | HPRR04 | HPRR04 | 873 | 00 | 200 | 200 | 400 | E | DFA | LND | L2 | P | R | PR23 | LUZ2 | PI | LND |  |  |
| HPRR06A |  | AG CS Fittings (R06A) PO/Fabr./Transport to Site | level of effort | 266d | 2010-04-06 A | 2011-04-19 A | P3R06AL SS | 100% |  |  |  |  |  |  |  |  |  | HPRR06A | HPRR06A | 873 | 00 | 200 | 200 | 400 | E | DFA | LND | L2 | P | R | PR23 | LUZ2 | PI | LND |  |  |
| HPR30 |  | Piping - Issue Material PO's | level of effort | 218d | 2010-06-07 A | 2011-04-11 A | P3R02L SS | 100% |  |  |  |  |  |  |  |  |  | HPR30 | HPR30 | 873 | 00 | 200 | 200 | 400 | E | DFA | LND | L2 | P | R | PR23 | LUZ2 | PI | LND |  |  |
| HPRR02 |  | UG GFK Pipes (R02) PO/Fabr./Transport to Site | level of effort | 198d | 2010-06-07 A | 2011-03-14 A | P3R02L SS | 100% |  |  |  |  |  |  |  |  |  | HPRR02 | HPRR02 | 873 | 00 | 200 | 200 | 400 | E | DFA | LND | L2 | P | R | PR23 | LUZ2 | PI | LND |  |  |
| HPRR02A |  | UG Cast Iron Pipes (R02A) PO/Fabr./Transport to Site | level of effort | 281d | 2010-06-15 A | 2011-07-15 A | P3R02AL SS, P3R02BL SS | 100% |  |  |  |  |  |  |  |  |  | HPRR02A | HPRR02A | 873 | 00 | 200 | 200 | 400 | E | DFA | LND | L2 | P | R | PR23 | LUZ2 | PI | LND |  |  |
| HPRR07 |  | Pipe Supports (R07) PO/Fabr./Transport to Site | level of effort | 221d | 2010-07-13 A | 2011-05-20 A | P3R07AL SS | 100% |  |  |  |  |  |  |  |  |  | HPRR07 | HPRR07 | 873 | 00 | 200 | 200 | 400 | E | DFA | LND | L2 | P | R | PR23 | LUZ2 | PI | LND |  |  |
| HPRR09B |  | Air Manifolds (R09B) PO/Fabr./Transport to Site | level of effort | 296d | 2010-08-20 A | 2011-10-13 | P3R09BL SS |  | 30d |  |  | -23d | 0d |  |  |  |  | HPRR09B | HPRR09B | 873 | 00 | 200 | 200 | 400 | E | DFA | LND | L2 | P | R | PR23 | LUZ2 | PI | LND |  |  |
| P3A25A |  | A25 Safety Showers - Prepare/Issue RFQ |  | 4d | 2010-10-04 A | 2010-10-07 A | E3A2512, E3A2510 | 100% |  |  |  |  |  |  |  |  |  | P3A25A | P3A25A | 860 | 00 | 200 | 200 | 400 | P | DEV | LND | 0 | P | R | PB91 | LUZ2 | E | LND | A25 | A25 |
| P3A25B |  | A25 Safety Showers - RFQ issued | milestone | 0d | 2010-10-07 A | 2010-10-07 A | P3A25A FF | 100% |  |  |  |  |  |  |  | 6,881.5 | 6,881.5 | P3A25B | P3A25B | 860 | 00 | 200 | 200 | 400 | P | DEV | LND | 0 | P | R | PB91 | LUZ2 | E | LND | A25 | A25 |
| P3A25C |  | A25 Safety Showers - Eval./Negotiation |  | 163d | 2010-10-22 A | 2011-06-10 A | E3A2520 FF, P3A25B | 100% |  |  |  |  |  |  |  |  |  | P3A25C | P3A25C | 860 | 00 | 200 | 200 | 400 | P |  | LND | 0 | P | R | PB92 | LUZ2 | E | LND | A25 | A25 |
| HPRR03B |  | Gaskets (R03B) PO/Fabr./Transport to Site | level of effort | 54d | 2010-12-13 A | 2011-02-28 A | P3R03BL SS | 100% |  |  |  |  |  |  |  |  |  | HPRR03B | HPRR03B | 873 | 00 | 200 | 200 | 400 | E | DFA | LND | L2 | P | R | PR23 | LUZ2 | PI | LND |  |  |
| HPRR03A |  | Bolting Mat. (R03A) PO/Fabr./Transport to Site | level of effort | 53d | 2010-12-14 A | 2011-02-28 A | P3R03AL SS | 100% |  |  |  |  |  |  |  |  |  | HPRR03A | HPRR03A | 873 | 00 | 200 | 200 | 400 | E | DFA | LND | L2 | P | R | PR23 | LUZ2 | PI | LND |  |  |
| HPRR01 |  | UG P I Valves (R01) PO/Fabr./Transport to Site | level of effort | 173d | 2011-02-05 A | 2011-10-06 | P3R01L SS |  | 25d | 2011-02-07 | 2011-10-06 | 16d | 0d |  |  |  |  | HPRR01 | HPRR01 | 873 | 00 | 200 | 200 | 400 | E | DFA | LND | L2 | P | R | PR23 | LUZ2 | PI | LND |  |  |
| HPRR09A |  | Exp. Joints (R09A) PO/Fabr./Transport to Site | level of effort | 144d | 2011-05-20 A | 2011-12-09 | P3R09AL SS |  | 70d |  |  | 5d | 0d |  |  |  |  | HPRR09A | HPRR09A | 873 | 00 | 200 | 200 | 400 | E | DFA | LND | L2 | P | R | PR23 | LUZ2 | PI | LND |  |  |
| P3A25F |  | A25 Safety Showers - Bid tab Client appr. |  | 5d | 2011-06-02 A | 2011-06-08 A | E3A2530 | 100% |  |  |  |  |  |  |  |  |  | P3A25F | P3A25F | 860 | 00 | 200 | 200 | 400 | P |  | PMT | 0 | P | R | PB12 | LUZ2 | E | PMT | A25 | A25 |
| P3A25D |  | A25 Safety Showers - PO issued | milestone | 0d | 2011-06-10 A | 2011-06-10 A | IMS-P-000060 FF, F2940 FF, E3A2530 FF, P3A25C FF, P3A25F FF | 100% |  |  |  |  |  |  |  | 34,408 | 34,408 | P3A25D | P3A25D | 860 | 00 | 200 | 200 | 400 | P |  | LND | 0 | P | R | PB93 | LUZ2 | P | LND | A25 | A25 |
| P3A25L |  | A25 Safety Showers - Lead Time/Fabrication |  | 173d | 2011-06-11 A | 2011-11-30 | P3A25D |  | 91d |  |  | -90d | 0d | 2011-11-30 | TB26 - 2 - Manuf and Delivy |  |  | P3A25L | P3A25L | 860 | 00 | 200 | 200 | 400 | P | DEL | LND | 0 | P | R | PB96 | LUZ2 | E | LND | A25 | A25 |
| P3A25G |  | A25 Gost R Certificate to russ. customs | milestone | 0d | 2011-10-12 | 2011-10-12 | P3A25N FF-90d |  |  |  |  | 0d | 90d |  | TB26 - 2 - Manuf and Delivy |  |  | P3A25G | P3A25G | 860 | 00 | 200 | 200 | 400 | P |  | LND | 0 | P | R | PB98 | LUZ2 | E | LND | A25 | A25 |
| P3A25X |  | A25 Safety Showers - Final Inspection | milestone | 0d | 2011-11-26 | 2011-11-26 | P3A25L FF-5d |  |  |  |  | -80d | 10d |  | TB26 - 2 - Manuf and Delivy | 61,934 |  | P3A25X | P3A25X | 860 | 00 | 200 | 200 | 400 | P |  | LND | 0 | P | R | PB97 | LUZ2 | E | LND | A25 | A25 |
| P3A25M |  | A25 Safety Showers - Goods deliv. FOB | milestone | 0d | 2011-12-05 | 2011-12-05 | P3A25X FF, P3A25L FF+5d |  |  |  |  | -90d | 0d |  | TB26 - 2 - Manuf and Delivy | 20,644.5 |  | P3A25M | P3A25M | 860 | 00 | 200 | 200 | 400 | P |  | LND | 0 | P | R | PB98 | LUZ2 | E | LND | A25 | A25 |
| P3A25N |  | A25 Safety Showers - Transport to Site |  | 35d | 2011-12-06 | 2012-01-12 | P3A25M |  |  |  |  | -90d | 0d |  | TB26 - 2 - Manuf and Delivy |  |  | P3A25N | P3A25N | 860 | 00 | 200 | 200 | 400 | P |  | LND | 0 | P | R | PB98 | LUZ2 | E | LND | A25 | A25 |

Notes:
- HPRR06B: UDF_Actictity Name (Russia): Надземные трубы из угл. стали (R06B), заказ на поставку/изготовление/транспортировка на площадку
- HPRR06: UDF_Actictity Name (Russia): Надземные фитинги из нерж. стали (R06), заказ на поставку/изготовление/транспортировка на площадку
- HPRR06C: UDF_Actictity Name (Russia): Надземные трубы из нерж. стали (R06C), заказ на поставку/изготовление/транспортировка на площадку
- HPRR04: UDF_Actictity Name (Russia): Надземные клапаны (R04), заказ на поставку/изготовление/транспортировка на площадку
- HPRR06A: UDF_Actictity Name (Russia): Надземные фитинги из угл. стали (R06A), заказ на поставку/изготовление/транспортировка на площадку
- HPR30: UDF_Actictity Name (Russia): Трубопроводы - Выпуск заказов на поставку материалов
- HPRR02: UDF_Actictity Name (Russia): Подземные трубопроводы GFK (R02), заказ на поставку/изготовление/транспортировка на площадку
- HPRR02A: UDF_Actictity Name (Russia): Подземные трубопроводы HDPE (R02A), заказ на поставку/изготовление/транспортировка на площадку
- HPRR07: UDF_Actictity Name (Russia): Трубные опоры (R07), заказ на поставку/изготовление/транспортировка на площадку
- HPRR09B: UDF_Actictity Name (Russia): Воздушные распределители (R09B), заказ на поставку/изготовление/транспортировка на площадку
- P3A25B: Expenses: 900A 6881.5
- HPRR03B: UDF_Actictity Name (Russia): Прокладки (R03B), заказ на поставку/изготовление/транспортировка на площадку
- HPRR03A: UDF_Actictity Name (Russia): Материалы болтовых соединений (R03A), заказ на поставку/изготовление/транспортировка на площадку
- HPRR01: UDF_Actictity Name (Russia): Подземные клапаны P I (R01), заказ на поставку/изготовление/транспортировка на площадку
- HPRR09A: UDF_Actictity Name (Russia): Трубные компенсаторы (R09A), заказ на поставку/изготовление/транспортировка на площадку
- P3A25D: Expenses: 900A 34408
- P3A25X: Expenses: 900A 61934
- P3A25M: Expenses: 900A 20644.5

| ID | WBS | Activity | Type | Duration | Start | Finish | Predecessors | Complete | Remaining | Total float | Free float | Expected finish | Calendar | Cost | Actual cost | UDF_SAVE ACTID | UDF_SAVE ACT ID | Department | Type of Work | Constr. Area | Inquiry/Order No | PMT-Area | PMT-Schedule Org | PMT-Discipline | PMT-Phase | PMT-Doc. Type | PMT-Respons. | Zeigen/n. Zeigen | WBS Phase | WBS Discipline | WBS Type of Work | WBS Objects | IMS | UPT | Pro Unit/DocCode |
| --- | --- | --- | --- | --- | --- | --- | --- | --- | --- | --- | --- | --- | --- | --- | --- | --- | --- | --- | --- | --- | --- | --- | --- | --- | --- | --- | --- | --- | --- | --- | --- | --- | --- | --- | --- |
|  | E | **E Electrical** |  |  | 2008-03-10 | 2011-11-09 |  |  |  |  |  |  |  |  |  |  |  |  |  |  |  |  |  |  |  |  |  |  |  |  |  |  |  |  |  |
| P3E04A |  | R. Gear Motors - Prepare/Issue RFQ |  | 5d | 2008-03-10 A | 2008-03-14 A | E3E0410 | 100% |  |  |  |  |  |  |  | P3E04A | P3E04A | 860 | E04 | 00 | 2KB2429 | 200 | 200 | 400 | P | DEV | LND | 0 | P | E | EE20 | LUZ2 | ELE | LND |  |
| P3E04B |  | R. Gear Motors - RFQ issued | milestone | 0d | 2008-03-15 A | 2008-03-15 A | P3E04A FF | 100% |  |  |  |  |  | 17,431.5 | 17,431.5 | P3E04B | P3E04B | 860 | E04 | 00 | 2KB2429 | 200 | 200 | 400 | P | DEV | LND | 0 | P | E | EE20 | LUZ2 | ELE | LND |  |
| P3E04C |  | R. Gear Motors - Eval./Negotiation |  | 74d | 2008-06-16 A | 2008-09-25 A | P3E04B, E3E0420 FF | 100% |  |  |  |  |  |  |  | P3E04C | P3E04C | 860 | E04 | 00 | 2KB2429 | 200 | 200 | 400 | P |  | LND | 0 | P | E | EE20 | LUZ2 | ELE | LND |  |
| F3100 |  | Electrical Procurement & Supply | level of effort | 611d | 2008-06-26 A | 2010-11-30 A | P3E02A SS, P3E01BA SS, F1980 SS+80d, P3E01AA SS | 100% |  |  |  |  |  |  |  | F3100 | F3100 | 860 |  | 00 |  | 200 |  |  | P |  |  |  | P | E | PE00 | LUZ2 | ELE | LND | 91 |
| HPEE04 |  | R.Gear Motors (E04) PO/Fabr./Transport to Site | level of effort | 630d | 2008-09-26 A | 2011-03-31 A | P3E04L SS | 100% |  |  |  |  |  |  |  | HPEE04 | HPEE04 | 874 |  | 00 |  | 200 | 200 | 400 | E | DFA | LND | L2 | P | E | PE93 | LUZ2 | ELE | LND |  |
| HPEE30 |  | Electrical - Issue Material PO's | level of effort | 545d | 2008-09-26 A | 2010-11-30 A | P3E04L SS, P3E01AL SS, P3E01BL SS, P3E02L SS | 100% |  |  |  |  |  |  |  | HPEE30 | HPEE30 | 874 |  | 00 |  | 200 | 200 | 400 | E | DFA | LND | L2 | P | E | PE93 | LUZ2 | ELE | LND |  |
| P3E04D |  | R. Gear Motors - PO issued | milestone | 0d | 2008-09-26 A | 2008-09-26 A | E3E0430 FF, P3E04C FF | 100% |  |  |  |  |  | 87,157.5 | 87,157.5 | P3E04D | P3E04D | 860 | E04 | 00 | 2KB2429 | 200 | 200 | 400 | P |  | LND | 0 | P | E | EE20 | LUZ2 | ELE | LND |  |
| P3E04L |  | R. Gear Motors - Lead Time/Fabrication |  | 605d | 2008-09-26 A | 2010-05-31 A | P3E04D | 100% |  |  |  |  | TB26 - 2 - Manuf and Delivy |  |  | P3E04L | P3E04L | 860 | E04 | 00 | 2KB2429 | 200 | 200 | 400 | P | DEL | LND | 0 | P | E | EE20 | LUZ2 | ELE | LND |  |
| P3E00A |  | E00 E&I Subcontract - Tender issued | milestone | 0d | 2009-08-17 A | 2009-08-17 A | P3C01A FF+5d, P3C00B FF+65d | 100% |  |  |  |  |  |  |  | P3E00A | P3E00A | 860 | E00 | 00 | 2MD6890 | 200 | 200 | 400 | P | DEV | LND | 0 | P | E | PM11 | LUZ2 | E | LND |  |
| P3E00H |  | E00 E&I Subcontract - Bid preparation |  | 78d | 2009-08-18 A | 2009-12-04 A | P3E00A | 100% |  |  |  |  |  |  |  | P3E00H | P3E00H | 860 | E00 | 00 | 2MD6890 | 200 | 200 | 400 | P | DEV | LND | 0 | P | E | PM11 | LUZ2 | E | LND |  |
| P3E00C |  | E00 E&I Subcontract - Evaluation Bids / questionnaire |  | 10d | 2009-12-14 A | 2009-12-29 A | P3E00H FS+5d | 100% |  |  |  |  |  |  |  | P3E00C | P3E00C | 860 | E00 | 00 | 2MD6890 | 200 | 200 | 400 | P | DEV | LND | 0 | P | E | PM11 | LUZ2 | E | LND |  |
| P3E01AF |  | E01A MV-SWG/MCC - Bid tab Client appr. |  | 6d | 2010-02-04 A | 2010-02-11 A | E3E01A30 | 100% |  |  |  |  |  |  |  | P3E01AF | P3E01AF | 860 | E01A | 00 | 2EB5640 | 200 | 200 | 400 | P |  | PMT | 0 | P | E | EE27 | LUZ2 | ELE | LND |  |
| P3E01BF |  | E01B LV-SWG/MCC/Softstarter/FQ - Bid tab Client appr. |  | 6d | 2010-02-04 A | 2010-02-11 A | E3E01B30 | 100% |  |  |  |  |  |  |  | P3E01BF | P3E01BF | 860 | E01B | 00 | 2EB5630 | 200 | 200 | 400 | P |  | PMT | 0 | P | E | EE27 | LUZ2 | ELE | LND |  |
| P3E02F |  | E02 PowerTransformer - Bid tab Client appr. |  | 6d | 2010-02-04 A | 2010-02-11 A | E3E0230 | 100% |  |  |  |  |  |  |  | P3E02F | P3E02F | 860 | E02 | 00 | 2EB5620 | 200 | 200 | 400 | P |  | PMT | 0 | P | E | EE27 | LUZ2 | ELE | LND |  |
| HPEE01A |  | MV SWG (E01A) PO/Fabr./Transport to Site | level of effort | 193d | 2010-03-01 A | 2010-12-01 A | P3E01AL SS | 100% |  |  |  |  |  |  |  | HPEE01A | HPEE01A | 87F |  | 00 |  | 200 | 200 | 400 | E | DFA | SC | L2 | P | E | PE93 | LUZ2 | E | LND |  |
| HPEE01B |  | LV SWG (E01B) PO/Fabr./Transport to Site | level of effort | 338d | 2010-03-01 A | 2011-06-24 A | P3E01BL SS | 100% |  |  |  |  |  |  |  | HPEE01B | HPEE01B | 87F |  | 00 |  | 200 | 200 | 400 | E | DFA | SC | L2 | P | E | PE93 | LUZ2 | E | LND |  |
| HPEE02 |  | Transormer (E02) PO/Fabr./Transport to Site | level of effort | 195d | 2010-03-01 A | 2010-12-03 A | P3E02L SS | 100% |  |  |  |  |  |  |  | HPEE02 | HPEE02 | 87F |  | 00 |  | 200 | 200 | 400 | E | DFA | SC | L2 | P | E | PE93 | LUZ2 | E | LND |  |
| P3E16A |  | E16 El.Cable Tray Syst. - Prepare/Issue RFQ |  | 4d | 2010-03-08 A | 2010-03-11 A | E3E1610 | 100% |  |  |  |  |  |  |  | P3E16A | P3E16A | 860 | E16 | 00 | E16 | 200 | 200 | 400 | P | DEV | LND | 0 | P | E | EE37 | LUZ2 | ELE | LND |  |
| P3E16B |  | E16 El.Cable Tray Syst. - RFQ issued | milestone | 0d | 2010-03-11 A | 2010-03-11 A | P3E16A FF | 100% |  |  |  |  |  |  |  | P3E16B | P3E16B | 860 | E16 | 00 | E16 | 200 | 200 | 400 | P | DEV | LND | 0 | P | E | EE37 | LUZ2 | ELE | LND |  |
| P3E00C1 |  | E00 E&I Subcontract - 1st Negotiations |  | 20d | 2010-03-29 A | 2010-04-27 A | P3E00C, P3A00H1 SS | 100% |  |  |  |  |  |  |  | P3E00C1 | P3E00C1 | 860 | E00 | 00 | 2MD6890 | 200 | 200 | 400 | P | DEV | LND | 0 | P | E | PM11 | LUZ2 | e&i | LND |  |
| P3E07F |  | E07 UPS/DC-System - Bid tab Client appr. |  | 5d | 2010-03-31 A | 2010-04-08 A | E3E0730 | 100% |  |  |  |  |  |  |  | P3E07F | P3E07F | 860 | E07 | 00 | 2EB5610 | 200 | 200 | 400 | P |  | PMT | 0 | P | E | EE27 | LUZ2 | ELE | LND |  |
| P3E13A |  | E13 CCTV System - Prepare/Issue RFQ |  | 2d | 2010-04-01 A | 2010-04-06 A | E3E1310 | 100% |  |  |  |  |  |  |  | P3E13A | P3E13A | 87G | E13 | 00 | 2EB6080 | 200 | 200 | 400 | P | DEV | UIO | 0 | P | E | EE43 | LUZ2 | ELE | LND |  |
| P3E13B |  | E13 CCTV System - RFQ issued | milestone | 0d | 2010-04-06 A | 2010-04-06 A | P3E13A FF | 100% |  |  |  |  |  |  |  | P3E13B | P3E13B | 87G | E13 | 00 | 2EB6080 | 200 | 200 | 400 | P | DEV | UIO | 0 | P | E | EE43 | LUZ2 | ELE | LND |  |
| P3E15AA |  | E15A Elec. MV Power Cable - Prepare/Issue RFQ |  | 5d | 2010-04-22 A | 2010-04-28 A | E3E15A10 | 100% |  |  |  |  |  |  |  | P3E15AA | P3E15AA | 860 | E15A | 00 | 2EB6110 | 200 | 200 | 400 | P | DEV | LND | 0 | P | E | EE26 | LUZ2 | ELE | LND |  |
| P3E00H1 |  | E00 E&I Subcontract - Preparation of rev. Bid's |  | 10d | 2010-04-28 A | 2010-05-11 A | P3E00C, P3E00C1 | 100% |  |  |  |  |  |  |  | P3E00H1 | P3E00H1 | 860 | E00 | 00 | 2MD6890 | 200 | 200 | 400 | P | DEV | LND | 0 | P | E | PM11 | LUZ2 | E | LND |  |
| P3E15AB |  | E15A Elec. MV Power Cable - RFQ issued | milestone | 0d | 2010-04-28 A | 2010-04-28 A | P3E15AA FF | 100% |  |  |  |  |  | 42,500 | 42,500 | P3E15AB | P3E15AB | 860 | E15A | 00 | 2EB6110 | 200 | 200 | 400 | P | DEV | LND | 0 | P | E | EE26 | LUZ2 | ELE | LND |  |
| P3E03A |  | E03 Distrib./Lighting Panel - Prepare/Issue RFQ |  | 3d | 2010-05-07 A | 2010-05-11 A | E3E0310 | 100% |  |  |  |  |  |  |  | P3E03A | P3E03A | 87E | E03 | 00 | 2EB6150 | 200 | 200 | 400 | P | DEV | LND | 0 | P | E | EE34 | LUZ2 | ELE | LND |  |
| P3E14A |  | E14 Local Switches/PushBS - Prepare/Issue RFQ |  | 3d | 2010-05-10 A | 2010-05-12 A | E3E1410 FS+3d | 100% |  |  |  |  |  |  |  | P3E14A | P3E14A | 87E | E14 | 00 | 2EB6120 | 200 | 200 | 400 | P | DEV | LND | 0 | P | E | EE36 | LUZ2 | ELE | LND |  |
| P3E03B |  | E03 Distrib./Lighting Panel - RFQ issued | milestone | 0d | 2010-05-11 A | 2010-05-11 A | P3E03A FF | 100% |  |  |  |  |  |  |  | P3E03B | P3E03B | 87E | E03 | 00 | 2EB6150 | 200 | 200 | 400 | P | DEV | LND | 0 | P | E | EE34 | LUZ2 | ELE | LND |  |
| P3E14B |  | E14 Local Switches/PushBS - RFQ issued | milestone | 0d | 2010-05-12 A | 2010-05-12 A | P3E14A FF | 100% |  |  |  |  |  |  |  | P3E14B | P3E14B | 87E | E14 | 00 | 2EB6120 | 200 | 200 | 400 | P | DEV | LND | 0 | P | E | EE36 | LUZ2 | ELE | LND |  |
| P3E00C2 |  | E00 E&I Subcontract - Final negotiations |  | 153d | 2010-05-12 A | 2010-12-15 A | P3E00H1 | 100% |  |  |  |  |  |  |  | P3E00C2 | P3E00C2 | 860 | E00 | 00 | 2MD6890 | 200 | 200 | 400 | P | DEV | LND | 0 | P | E | PM11 | LUZ2 | E | LND |  |
| P3E15BA |  | E15B Elec. LV Power Cable - Prepare/Issue RFQ |  | 5d | 2010-05-18 A | 2010-05-25 A | E3E15B05, E3E15B10 | 100% |  |  |  |  |  |  |  | P3E15BA | P3E15BA | 860 | E15B | 00 | 2EB6200 | 200 | 200 | 400 | P | DEV | LND | 0 | P | E | EE30 | LUZ2 | ELE | LND |  |
| P3E04X |  | R. Gear Motors - Final Inspection | milestone | 0d | 2010-05-22 A | 2010-05-22 A | E3E0450 FF, P3E04L FF-10d | 100% |  |  |  |  | TB26 - 2 - Manuf and Delivy | 156,883.5 | 156,883.5 | P3E04X | P3E04X | 860 | E04 | 00 | 2KB2429 | 200 | 200 | 400 | P |  | LND | 0 | P | E | EE20 | LUZ2 | ELE | LND |  |
| P3E15BB |  | E15B Elec. LV Power Cable - RFQ issued | milestone | 0d | 2010-05-25 A | 2010-05-25 A | P3E15BA FF | 100% |  |  |  |  |  | 25,000 | 25,000 | P3E15BB | P3E15BB | 860 | E15B | 00 | 2EB6200 | 200 | 200 | 400 | P | DEV | LND | 0 | P | E | EE30 | LUZ2 | ELE | LND |  |
| P3E15AC |  | E15A Elec. MV Power Cable - Eval./Negotiation |  | 206d | 2010-05-28 A | 2011-03-16 A | P3E15AB, E3E15A20 FF | 100% |  |  |  |  |  |  |  | P3E15AC | P3E15AC | 860 | E15A | 00 | 2EB6110 | 200 | 200 | 400 | P |  | LND | 0 | P | E | EE26 | LUZ2 | ELE | LND |  |
| P3E04M |  | R. Gear Motors - Goods deliv. FCA | milestone | 0d | 2010-05-31 A | 2010-05-31 A | P3E04X FF, P3E04L FF | 100% |  |  |  |  | TB26 - 2 - Manuf and Delivy | 52,294.5 | 52,294.5 | P3E04M | P3E04M | 860 | E04 | 00 | 2KB2429 | 200 | 200 | 400 | P |  | LND | 0 | P | E | EE20 | LUZ2 | ELE | LND |  |
| P3E04M1 |  | R. Gear Motors - storage period Motors |  | 150d | 2010-06-01 A | 2010-10-28 A | P3E04M | 100% |  |  |  |  | TB26 - 2 - Manuf and Delivy |  |  | P3E04M1 | P3E04M1 | 860 | E04 | 00 | 2KB2429 | 200 | 200 | 400 | P |  | LND | 0 | P | E | EE20 | LUZ2 | ELE | LND |  |
| P3E15CA |  | E15C Cable Glands - Prepare/Issue RFQ |  | 7d | 2010-06-07 A | 2010-06-15 A | E3E15C10 FS+2d | 100% |  |  |  |  |  |  |  | P3E15CA | P3E15CA | 860 | E15C | 00 | 2EB6210 | 200 | 200 | 400 | P | DEV | LND | 0 | P | E | EE37 | LUZ2 | ELE | LND |  |
| P3E19A |  | E19 Heat Tracing Syst. - Prepare/Issue RFQ |  | 4d | 2010-06-09 A | 2010-06-14 A | E3E1910 | 100% |  |  |  |  |  |  |  | P3E19A | P3E19A | 87F | E19 | 00 | 2EB5180 | 200 | 200 | 400 | P | DEV | LND | 0 | P | E | EE39 | LUZ2 | ELE | LND |  |
| P3E19B |  | E19 Heat Tracing Syst. - RFQ issued | milestone | 0d | 2010-06-14 A | 2010-06-14 A | P3E19A FF | 100% |  |  |  |  |  | 150,000 | 150,000 | P3E19B | P3E19B | 87F | E19 | 00 | 2EB5180 | 200 | 200 | 400 | P | DEV | LND | 0 | P | E | EE39 | LUZ2 | ELE | LND |  |
| P3E15CB |  | E15C Cable Glands - RFQ issued | milestone | 0d | 2010-06-16 A | 2010-06-16 A | P3E15CA FF | 100% |  |  |  |  |  |  |  | P3E15CB | P3E15CB | 860 | E15C | 00 | 2EB6210 | 200 | 200 | 400 | P | DEV | LND | 0 | P | E | EE37 | LUZ2 | ELE | LND |  |
| P3E03C |  | E03 Distrib./Lighting Panel - Eval./Negotiation |  | 113d | 2010-07-09 A | 2010-12-15 A | P3E03B, E3E0320 FF | 100% |  |  |  |  |  |  |  | P3E03C | P3E03C | 87E | E03 | 00 | 2EB6150 | 200 | 200 | 400 | P |  | LND | 0 | P | E | EE34 | LUZ2 | ELE | LND |  |
| P3E14C |  | E14 Local Switches/PushBS - Eval./Negotiation |  | 113d | 2010-07-09 A | 2010-12-15 A | E3E1420 FF, P3E14B | 100% |  |  |  |  |  |  |  | P3E14C | P3E14C | 87E | E14 | 00 | 2EB6120 | 200 | 200 | 400 | P |  | LND | 0 | P | E | EE36 | LUZ2 | ELE | LND |  |
| P3E15BC |  | E15B Elec. LV Power Cable - Eval./Negotiation |  | 197d | 2010-07-14 A | 2011-04-19 A | E3E15B20 FF, P3E15BB | 100% |  |  |  |  |  |  |  | P3E15BC | P3E15BC | 860 | E15B | 00 | 2EB6200 | 200 | 200 | 400 | P |  | LND | 0 | P | E | EE30 | LUZ2 | ELE | LND |  |
| P3E15CC |  | E15C Cable Glands - Eval./Negotiation |  | 196d | 2010-07-15 A | 2011-04-19 A | P3E15CB, E3E15C20 FF | 100% |  |  |  |  |  |  |  | P3E15CC | P3E15CC | 860 | E15C | 00 | 2EB6210 | 200 | 200 | 400 | P |  | LND | 0 | P | E | EE37 | LUZ2 | ELE | LND |  |
| P3E19C |  | E19 Heat Tracing Syst. - Eval./Negotiation |  | 94d | 2010-07-21 A | 2010-11-30 A | E3E1920 FF, P3E19B | 100% |  |  |  |  |  |  |  | P3E19C | P3E19C | 87F | E19 | 00 | 2EB5180 | 200 | 200 | 400 | P |  | LND | 0 | P | E | EE39 | LUZ2 | ELE | LND |  |
| P3E13C |  | E13 CCTV System - Eval./Negotiation |  | 223d | 2010-08-12 A | 2011-06-23 A | E3E1320 FF, P3E13B | 100% |  |  |  |  |  |  |  | P3E13C | P3E13C | 87G | E13 | 00 | 2EB6080 | 200 | 200 | 400 | P |  | UIO | 0 | P | E | EE43 | LUZ2 | ELE | LND |  |
| P3E04N |  | R. Gear Motors - Transport to Lufkin (France) |  | 3d | 2010-10-29 A | 2010-10-31 A | P3E04M, P3E04M1 | 100% |  |  |  |  | TB26 - 2 - Manuf and Delivy | 34,863 | 34,863 | P3E04N | P3E04N | 860 | E04 | 00 | 2KB2429 | 200 | 200 | 400 | P |  | OWN | 0 | P | E | EE20 | LUZ2 | ELE | LND |  |
| P3E03F |  | E03 Distrib./Lighting Panel - Bid tab Client appr. |  | 5d | 2010-11-01 A | 2010-11-05 A |  | 100% |  |  |  |  |  |  |  | P3E03F | P3E03F | 860 | E03 | 00 | 2EB6150 | 200 | 200 | 400 | P |  | PMT | 0 | P | E | EE27 | LUZ2 | ELE | LND |  |
| P3E15AF |  | E15A Elec. MV Power Cable - Bid tab Client appr. |  | 84d | 2010-11-05 A | 2011-03-07 A | E3E15A30 | 100% |  |  |  |  |  |  |  | P3E15AF | P3E15AF | 860 | E15A | 00 | 2EB6110 | 200 | 200 | 400 | P |  | PMT | 0 | P | E | EE26 | LUZ2 | ELE | LND |  |
| P3E15BF |  | E15B Elec. LV Power Cable - Bid tab Client appr. |  | 105d | 2010-11-05 A | 2011-04-05 A | E3E15B30 | 100% |  |  |  |  |  |  |  | P3E15BF | P3E15BF | 860 | E15B | 00 | 2EB6200 | 200 | 200 | 400 | P |  | PMT | 0 | P | E | EE30 | LUZ2 | ELE | LND |  |
| P3E15CF |  | E15C Cable Glands - Bid tab Client appr. |  | 105d | 2010-11-05 A | 2011-04-05 A | E3E15C30 | 100% |  |  |  |  |  |  |  | P3E15CF | P3E15CF | 860 | E15C | 00 | 2EB6210 | 200 | 200 | 400 | P |  | PMT | 0 | P | E | EE37 | LUZ2 | ELE | LND |  |
| P3E16D |  | E16 El.Cable Tray Syst. - PO issued | milestone | 0d | 2010-11-09 A | 2010-11-09 A | E3E1640, E3E1620 FF, E3E1630 | 100% |  |  |  |  |  |  |  | P3E16D | P3E16D | 860 | E16 | 00 | E16 | 200 | 200 | 400 | P |  | LND | 0 | P | E | EE37 | LUZ2 | ELE | LND |  |
| P3E19D |  | E19 Heat Tracing Syst. - PO issued | milestone | 0d | 2010-11-30 A | 2010-11-30 A | HPEE30 FF, F3100 FF, P3E19C FF | 100% |  |  |  |  |  | 750,000 | 750,000 | P3E19D | P3E19D | 87F | E19 | 00 | 2EB5180 | 200 | 200 | 400 | P |  | LND | 0 | P | E | EE39 | LUZ2 | ELE | LND |  |
| HPEE19 |  | Heat Tracing (E19) PO/Fabr./Transport to Site | level of effort | 169d | 2010-12-01 A | 2011-07-27 A | P3E19L SS | 100% |  |  |  |  |  |  |  | HPEE19 | HPEE19 | 87F |  | 00 |  | 200 | 200 | 400 | E | DFA | SC | L2 | P | E | PE93 | LUZ2 | ELE | LND |  |
| P3E19L |  | E19 Heat Tracing Syst. -Lead Time/Fabrication |  | 178d | 2010-12-01 A | 2011-05-31 A | P3E19D | 100% |  |  |  |  | TB26 - 2 - Manuf and Delivy |  |  | P3E19L | P3E19L | 87F | E19 | 00 | 2EB5180 | 200 | 200 | 400 | P | DEL | SC | 0 | P | E | EE39 | LUZ2 | ELE | LND |  |
| P3E03D |  | E03 Distrib./Lighting Panel - PO issued | milestone | 0d | 2010-12-15 A | 2010-12-15 A | E3E0335, P3E03C FF, P3E03F FF | 100% |  |  |  |  |  |  |  | P3E03D | P3E03D | 87E | E03 | 00 | 2EB6150 | 200 | 200 | 400 | P |  | LND | 0 | P | E | EE34 | LUZ2 | ELE | LND |  |
| P3E14D |  | E14 Local Switches/PushBS - PO issued | milestone | 0d | 2010-12-15 A | 2010-12-15 A | P3E14C FF | 100% |  |  |  |  |  |  |  | P3E14D | P3E14D | 87E | E14 | 00 | 2EB6120 | 200 | 200 | 400 | P |  | LND | 0 | P | E | EE36 | LUZ2 | ELE | LND |  |
| HPEE14 |  | Local Switches (E14) PO/Fabr./Transport to Site | level of effort | 206d | 2010-12-16 A | 2011-10-04 | P3E14L SS |  | 23d | 86d | 0d |  |  |  |  | HPEE14 | HPEE14 | 87E |  | 00 |  | 200 | 200 | 400 | E | DFA | CC | L2 | P | E | PE93 | LUZ2 | ELE | LND |  |
| P3E14L |  | E14 Local Switches/PushBS - Lead Time/Fabrication |  | 274d | 2010-12-16 A | 2011-09-19 | P3E14D | 100% | 19d | 121d | 0d | 2011-09-19 | TB26 - 2 - Manuf and Delivy |  |  | P3E14L | P3E14L | 87E | E14 | 00 | 2EB6120 | 200 | 200 | 400 | P | DEL | LND | 0 | P | E | EE36 | LUZ2 | ELE | LND |  |
| P3E00D |  | E00 E&I Subcontract - Contract award | milestone | 0d | 2010-12-21 A | 2010-12-21 A | E3E1635, E3J0940, E3E0935 FF, P3E00C2 FF | 100% |  |  |  |  |  |  |  | P3E00D | P3E00D | 860 | E00 | 00 | 2MD6890 | 200 | 200 | 400 | P | DEV | CC | 0 | P | E | PM11 | LUZ2 | E | LND |  |
| HPEE09 |  | Lighting (E09) PO/Fabr./Transport to Site | level of effort | 155d | 2010-12-22 A | 2011-07-28 A | P3E00D | 100% |  |  |  |  |  |  |  | HPEE09 | HPEE09 | 87E |  | 00 |  | 200 | 200 | 400 | E | DFA | CC | L2 | P | E | PE93 | LUZ2 | ELE | LND |  |
| HPEE16 |  | Cable Tray S. (E16) PO/Fabr./Transport to Site | level of effort | 76d | 2010-12-22 A | 2011-04-08 A | P3E00D | 100% |  |  |  |  |  |  |  | HPEE16 | HPEE16 | 87E |  | 00 |  | 200 | 200 | 400 | E | DFA | CC | L2 | P | E | PE93 | LUZ2 | ELE | LND |  |
| P3E00L |  | E00 E&I Subcontract - Vendor Procurement/Delivery |  | 179d | 2010-12-22 A | 2011-08-31 A | P3E00D | 100% |  |  |  |  |  |  |  | P3E00L | P3E00L | 860 | E00 | 00 | 2MD6890 | 200 | 200 | 400 | P | DEV | CC | 0 | P | E | PM11 | LUZ2 | E | LND |  |
| P3E03L |  | E03 Distrib./Lighting Panel - Lead Time/Fabrication |  | 194d | 2011-01-02 A | 2011-07-15 A | P3E03D | 100% |  |  |  |  | TB26 - 2 - Manuf and Delivy |  |  | P3E03L | P3E03L | 87E | E03 | 00 | 2EB6150 | 200 | 200 | 400 | P | DEL | LND | 0 | P | E | EE34 | LUZ2 | ELE | LND |  |
| HPEE03 |  | Distr. Panels (E03) PO/Fabr./Transport to Site | level of effort | 146d | 2011-01-03 A | 2011-07-25 A | P3E03L SS | 100% |  |  |  |  |  |  |  | HPEE03 | HPEE03 | 87E |  | 00 |  | 200 | 200 | 400 | E | DFA | CC | L2 | P | E | PE93 | LUZ2 | ELE | LND |  |
| P3E19G |  | E19 Gost R Certificate to russ. customs | milestone | 0d | 2011-03-09 A | 2011-03-09 A | P3E19N FF-90d | 100% |  |  |  |  | TB26 - 2 - Manuf and Delivy |  |  | P3E19G | P3E19G | 87F | E19 | 00 | 2EB5180 | 200 | 200 | 400 | P |  | SC | 0 | P | E | EE39 | LUZ2 | ELE | LND |  |
| P3E15AD |  | E15A Elec. MV Power Cable - PO issued | milestone | 0d | 2011-03-16 A | 2011-03-16 A | P3E15AC FF, P3E15AF | 100% |  |  |  |  |  | 212,500 | 212,500 | P3E15AD | P3E15AD | 860 | E15A | 00 | 2EB6110 | 200 | 200 | 400 | P |  | LND | 0 | P | E | EE26 | LUZ2 | ELE | LND |  |
| HPEE15A |  | MV Cables (E15A) PO/Fabr./Transport to Site | level of effort | 159d | 2011-03-17 A | 2011-10-26 | P3E15CL SS, P3E15BL SS, P3E15AL SS |  | 39d | -40d | 0d |  |  |  |  | HPEE15A | HPEE15A | 87D |  | 00 |  | 200 | 200 | 400 | E | DFA | LND | L2 | P | E | PE93 | LUZ2 | ELE | LND |  |

Notes:
- P3E04B: Expenses: 900A 17431.5
- HPEE04: UDF_Actictity Name (Russia): Редукторные электродвигатели (E04), заказ на поставку/изготовление/транспортировка на площадку
- HPEE30: UDF_Actictity Name (Russia): Электрооборудование - Выпуск заказов на поставку материалов
- P3E04D: Expenses: 900A 87157.5
- P3E00A: Expenses: 900A 0
- HPEE01A: UDF_Actictity Name (Russia): ВВ распредустройства (E01A), заказ на поставку/изготовление/транспортировка на площадку
- HPEE01B: UDF_Actictity Name (Russia): НВ распредустройства (E01B), заказ на поставку/изготовление/транспортировка на площадку
- HPEE02: UDF_Actictity Name (Russia): Трансформаторы (E02), заказ на поставку/изготовление/транспортировка на площадку
- P3E13B: Expenses: 900A 0
- P3E15AB: Expenses: 900A 42500
- P3E03B: Expenses: 900A 0
- P3E14B: Expenses: 900A 0
- P3E04X: Expenses: 900A 156884
- P3E15BB: Expenses: 900A 25000
- P3E04M: Expenses: 900A 52294.5
- P3E19B: Expenses: 900A 150000
- P3E04N: Expenses: 900A 34863
- P3E15AF: Scope: 11.01.11 B.RoЯberg -new inquiry required by client- / delayed bid tab approval
- P3E19D: Expenses: 900A 750000
- HPEE19: UDF_Actictity Name (Russia): Теплоспутники (E19), заказ на поставку/изготовление/транспортировка на площадку
- P3E03D: Scope: 11.01.11 -B. RoЯberg: part of E&I / contract / Expenses: 900A 0
- P3E14D: Scope: 11.01.11 -B. RoЯberg: part of E&I contract / Expenses: 900A 0
- HPEE14: UDF_Actictity Name (Russia): Локальные переключатели (E14), заказ на поставку/изготовление/транспортировка на площадку
- P3E00D: Expenses: 900A 0
- HPEE09: UDF_Actictity Name (Russia): Освещение (E09), заказ на поставку/изготовление/транспортировка на площадку
- HPEE16: UDF_Actictity Name (Russia): Система кабельных лотков (E16), заказ на поставку/изготовление/транспортировка на площадку
- HPEE03: UDF_Actictity Name (Russia): Распределительные панели (E03), заказ на поставку/изготовление/транспортировка на площадку
- P3E15AD: Scope: 11.01.11 B.RoЯberg -new inquiry required by client- / delayed bid tab approval / Expenses: 900A 212500
- HPEE15A: UDF_Actictity Name (Russia): ВВ кабели (E15A), заказ на поставку/изготовление/транспортировка на площадку

| ID | Activity | Type | Duration | Start | Finish | Predecessors | Complete | Remaining | Planned start | Planned finish | Total float | Free float | Expected finish | Calendar | Cost | Actual cost | UDF_SAVE ACTID | UDF_SAVE ACT ID | Department | Type of Work | Constr. Area | Inquiry/Order No | PMT-Area | PMT-Schedule Org | PMT-Discipline | PMT-Phase | PMT-Doc. Type | PMT-Respons. | Zeigen/n. Zeigen | WBS Phase | WBS Discipline | WBS Type of Work | WBS Objects | IMS | UPT |
| --- | --- | --- | --- | --- | --- | --- | --- | --- | --- | --- | --- | --- | --- | --- | --- | --- | --- | --- | --- | --- | --- | --- | --- | --- | --- | --- | --- | --- | --- | --- | --- | --- | --- | --- | --- |
| P3E15AL | E15A Elec. MV Power Cable - Lead Time/Fabrication |  | 97d | 2011-03-17 A | 2011-06-22 A | P3E15AD | 100% |  |  |  |  |  |  | TB26 - 2 - Manuf and Delivy |  |  | P3E15AL | P3E15AL | 860 | E15A | 00 | 2EB6110 | 200 | 200 | 400 | P | DEL | LND | 0 | P | E | EE26 | LUZ2 | ELE | LND |
| P3E15BD | E15B Elec. LV Power Cable - PO issued (LOI) | milestone | 0d | 2011-04-19 A | 2011-04-19 A | P3E15BC FF, P3E15BF | 100% |  |  |  |  |  |  |  | 125,000 | 125,000 | P3E15BD | P3E15BD | 860 | E15B | 00 | 2EB6200 | 200 | 200 | 400 | P |  | LND | 0 | P | E | EE30 | LUZ2 | ELE | LND |
| P3E15CD | E15C Cable Glands - PO issued | milestone | 0d | 2011-04-19 A | 2011-04-19 A | P3E15CF, P3E15CC FF | 100% |  |  |  |  |  |  |  |  |  | P3E15CD | P3E15CD | 860 | E15C | 00 | 2EB6210 | 200 | 200 | 400 | P |  | LND | 0 | P | E | EE37 | LUZ2 | ELE | LND |
| HPEE15B | LV Cables (E15B) PO/Fabr./Transport to Site | level of effort | 114d | 2011-04-20 A | 2011-09-26 | P3E15BL SS |  | 18d |  |  | 30d | 0d |  |  |  |  | HPEE15B | HPEE15B | 87E |  | 00 |  | 200 | 200 | 400 | E | DFA | CC | L2 | P | E | PE93 | LUZ2 | ELE | LND |
| HPEE15C | Cables Glands (E15C) PO/Fabr./Transport to Site | level of effort | 141d | 2011-04-20 A | 2011-11-04 | P3E15CL SS |  | 45d |  |  | 3d | 0d |  |  |  |  | HPEE15C | HPEE15C | 87E |  | 00 |  | 200 | 200 | 400 | E | DFA | CC | L2 | P | E | PE93 | LUZ2 | ELE | LND |
| P3E15BL | E15B Elec. LV Power Cable - Lead Time/Fabrication |  | 107d | 2011-04-20 A | 2011-08-05 A | P3E15BD | 100% |  |  |  |  |  |  | TB26 - 2 - Manuf and Delivy |  |  | P3E15BL | P3E15BL | 860 | E15B | 00 | 2EB6200 | 200 | 200 | 400 | P | DEL | LND | 0 | P | E | EE30 | LUZ2 | ELE | LND |
| P3E15CL | E15C Cable Glands - Lead Time/Fabrication |  | 163d | 2011-04-20 A | 2011-09-30 | P3E15CD |  | 30d |  |  | 5d | 0d | 2011-09-30 | TB26 - 2 - Manuf and Delivy |  |  | P3E15CL | P3E15CL | 860 | E15C | 00 | 2EB6210 | 200 | 200 | 400 | P | DEL | LND | 0 | P | E | EE37 | LUZ2 | ELE | LND |
| P3E15AG | E15A Gost R Certificate to russ. customs | milestone | 0d | 2011-05-04 A | 2011-05-04 A | P3E15AN FF-60d | 100% |  |  |  |  |  |  | TB26 - 2 - Manuf and Delivy |  |  | P3E15AG | P3E15AG | 860 | E15A | 00 | 2EB6110 | 200 | 200 | 400 | P |  | LND | 0 | P | E | EE26 | LUZ2 | ELE | LND |
| P3E19X | E19 Heat Tracing Syst. - Final Inspection | milestone | 0d | 2011-05-23 A | 2011-05-23 A | E3E1950, P3E19L FF-9d | 100% |  |  |  |  |  |  | TB26 - 2 - Manuf and Delivy | 1,350,000 | 1,350,000 | P3E19X | P3E19X | 87F | E19 | 00 | 2EB5180 | 200 | 200 | 400 | P |  | SC | 0 | P | E | EE39 | LUZ2 | ELE | LND |
| P3E15AX | E15A Elec. MV Power Cable - Final Inspection | milestone | 0d | 2011-05-24 A | 2011-05-24 A | P3E15AL FF-30d | 100% |  |  |  |  |  |  | TB26 - 2 - Manuf and Delivy | 382,500 | 382,500 | P3E15AX | P3E15AX | 860 | E15A | 00 | 2EB6110 | 200 | 200 | 400 | P |  | LND | 0 | P | E | EE26 | LUZ2 | ELE | LND |
| P3E00S | E00 E&I Subcontract - Delivery Bulk Material |  | 110d | 2011-05-27 A | 2011-10-28 | IMS-P-000170 (other project) FF, P3E00L SS+110d |  | 41d |  |  | 139d | 150.5d |  |  |  |  | P3E00S | P3E00S | 860 | E00 | 00 | 2MD6890 | 200 | 200 | 400 | P | DEV | CC | 0 | P | E | PM11 | LUZ2 | E | LND |
| P3E19M | E19 Heat Tracing Syst. - Goods deliv. FOB | milestone | 0d | 2011-06-15 A | 2011-06-15 A | P3E19L FF+15d, P3E19X FF | 100% |  |  |  |  |  |  | TB26 - 2 - Manuf and Delivy | 450,000 | 450,000 | P3E19M | P3E19M | 87F | E19 | 00 | 2EB5180 | 200 | 200 | 400 | P |  | SC | 0 | P | E | EE39 | LUZ2 | ELE | LND |
| HPEE13 | Commun.Syst. (E13) PO/Fabr./Transport to Site | level of effort | 97d | 2011-06-23 A | 2011-11-09 | P3E13D |  | 48d | 2011-06-24 | 2011-11-09 | 308.5d | 0d |  |  |  |  | HPEE13 | HPEE13 | 87G |  | 00 |  | 200 | 200 | 400 | E | DFA | UIO | L2 | P | E | PE93 | LUZ2 | ELE | LND |
| P3E19N | E19 Heat Tracing Syst. - Transport to Site |  | 31d | 2011-06-27 A | 2011-07-27 A | P3E100 FF, P3E19M | 100% |  |  |  |  |  |  | TB26 - 2 - Manuf and Delivy |  |  | P3E19N | P3E19N | 87F | E19 | 00 | 2EB5180 | 200 | 200 | 400 | P |  | SC | 0 | P | E | EE39 | LUZ2 | ELE | LND |
| P3E15AM | E15A Elec. MV Power Cable - Goods deliv. FOB | milestone | 0d | 2011-06-29 A | 2011-06-29 A | P3E15AX FF, P3E15AL FF-15d | 100% |  |  |  |  |  |  | TB26 - 2 - Manuf and Delivy | 127,500 | 127,500 | P3E15AM | P3E15AM | 860 | E15A | 00 | 2EB6110 | 200 | 200 | 400 | P |  | LND | 0 | P | E | EE26 | LUZ2 | ELE | LND |
| P3E03X | E03 Distrib./Lighting Panel - Final Inspection | milestone | 0d | 2011-07-06 A | 2011-07-06 A | P3E03L FF-10d | 100% |  |  |  |  |  |  | TB26 - 2 - Manuf and Delivy |  |  | P3E03X | P3E03X | 87E | E03 | 00 | 2EB6150 | 200 | 200 | 400 | P |  | LND | 0 | P | E | EE34 | LUZ2 | ELE | LND |
| P3E15BG | E15B Gost R Certificate to russ. customs | milestone | 0d | 2011-07-09 A | 2011-07-09 A | P3E15BN FF-60d | 100% |  |  |  |  |  |  | TB26 - 2 - Manuf and Delivy |  |  | P3E15BG | P3E15BG | 860 | E15B | 00 | 2EB6200 | 200 | 200 | 400 | P |  | LND | 0 | P | E | EE30 | LUZ2 | ELE | LND |
| P3E03M | E03 Distrib./Lighting Panel - Goods deliv. FOB | milestone | 0d | 2011-07-15 A | 2011-07-15 A | P3E03L FF, P3E03X FF | 100% |  |  |  |  |  |  | TB26 - 2 - Manuf and Delivy |  |  | P3E03M | P3E03M | 87E | E03 | 00 | 2EB6150 | 200 | 200 | 400 | P |  | LND | 0 | P | E | EE34 | LUZ2 | ELE | LND |
| P3E03N | E03 Distrib./Lighting Panel - Transport to Site |  | 10d | 2011-07-16 A | 2011-07-25 A | P3E03M | 100% |  |  |  |  |  |  | TB26 - 2 - Manuf and Delivy |  |  | P3E03N | P3E03N | 87E | E03 | 00 | 2EB6150 | 200 | 200 | 400 | P |  | LND | 0 | P | E | EE34 | LUZ2 | ELE | LND |
| P3E15BX | E15B Elec. LV Power Cable - Final Inspection | milestone | 0d | 2011-07-29 A | 2011-07-29 A | P3E15BL FF-8d | 100% |  |  |  |  |  |  | TB26 - 2 - Manuf and Delivy | 225,000 | 225,000 | P3E15BX | P3E15BX | 860 | E15B | 00 | 2EB6200 | 200 | 200 | 400 | P |  | LND | 0 | P | E | EE30 | LUZ2 | ELE | LND |
| P3E15BM | E15B Elec. LV Power Cable - Goods deliv. FOB | milestone | 0d | 2011-08-25 A | 2011-08-25 A | P3E15BX FF, P3E15BL FF+20d | 100% |  |  |  |  |  |  | TB26 - 2 - Manuf and Delivy | 75,000 | 75,000 | P3E15BM | P3E15BM | 860 | E15B | 00 | 2EB6200 | 200 | 200 | 400 | P |  | LND | 0 | P | E | EE30 | LUZ2 | ELE | LND |
| P3E15BN | E15B Elec. LV Power Cable - Transport to Site |  | 25d | 2011-09-02 | 2011-09-26 | P3E15BM FS+7d |  |  |  |  | 44d | 0d |  | TB26 - 2 - Manuf and Delivy |  |  | P3E15BN | P3E15BN | 860 | E15B | 00 | 2EB6200 | 200 | 200 | 400 | P |  | LND | 0 | P | E | EE30 | LUZ2 | ELE | LND |
| P3E15CG | E15C Gost R Certificate to russ. customs | milestone | 0d | 2011-09-06 | 2011-09-06 | P3E15CN FF-60d |  |  |  |  | 65d | 60d |  | TB26 - 2 - Manuf and Delivy |  |  | P3E15CG | P3E15CG | 860 | E15C | 00 | 2EB6210 | 200 | 200 | 400 | P |  | LND | 0 | P | E | EE37 | LUZ2 | ELE | LND |
| P3E14X | E14 Local Switches/PushBS - Final Inspection | milestone | 0d | 2011-09-10 | 2011-09-10 | P3E14L FF-10d |  |  |  |  | 136d | 15d |  | TB26 - 2 - Manuf and Delivy |  |  | P3E14X | P3E14X | 87E | E14 | 00 | 2EB6120 | 200 | 200 | 400 | P |  | LND | 0 | P | E | EE36 | LUZ2 | ELE | LND |
| P3E15CX | E15C Cable Glands - Final Inspection | milestone | 0d | 2011-09-21 | 2011-09-21 | P3E15CL FF-10d |  |  |  |  | 25d | 20d |  | TB26 - 2 - Manuf and Delivy |  |  | P3E15CX | P3E15CX | 860 | E15C | 00 | 2EB6210 | 200 | 200 | 400 | P |  | LND | 0 | P | E | EE37 | LUZ2 | ELE | LND |
| P3E14M | E14 Local Switches/PushBS - Goods deliv. FOB | milestone | 0d | 2011-09-24 | 2011-09-24 | P3E14X FF, P3E14L FF+5d |  |  |  |  | 121d | 0d |  | TB26 - 2 - Manuf and Delivy |  |  | P3E14M | P3E14M | 87E | E14 | 00 | 2EB6120 | 200 | 200 | 400 | P |  | LND | 0 | P | E | EE36 | LUZ2 | ELE | LND |
| P3E14N | E14 Local Switches/PushBS - Transport to Site |  | 10d | 2011-09-25 | 2011-10-04 | P3E14M |  |  |  |  | 121d | 0d |  | TB26 - 2 - Manuf and Delivy |  |  | P3E14N | P3E14N | 87E | E14 | 00 | 2EB6120 | 200 | 200 | 400 | P |  | LND | 0 | P | E | EE36 | LUZ2 | ELE | LND |
| P3E15AN | E15A Elec. MV Power Cable - Transport to Site on hold, spec. clarifications ongoing |  | 30d | 2011-09-27 | 2011-10-26 | P3E100 FF, P3E15AM FS+90d |  |  |  |  | -57d | 0d |  | TB26 - 2 - Manuf and Delivy |  |  | P3E15AN | P3E15AN | 860 | E15A | 00 | 2EB6110 | 200 | 200 | 400 | P |  | LND | 0 | P | E | EE26 | LUZ2 | ELE | LND |
| P3E15CM | E15C Cable Glands - Goods deliv. FOB | milestone | 0d | 2011-10-10 | 2011-10-10 | P3E15CL FF+10d, P3E15CX FF |  |  |  |  | 5d | 0d |  | TB26 - 2 - Manuf and Delivy |  |  | P3E15CM | P3E15CM | 860 | E15C | 00 | 2EB6210 | 200 | 200 | 400 | P |  | LND | 0 | P | E | EE37 | LUZ2 | ELE | LND |
| P3E15CN | E15C Cable Glands - Transport to Site |  | 25d | 2011-10-11 | 2011-11-04 | P3E15CM |  |  |  |  | 5d | 0d |  | TB26 - 2 - Manuf and Delivy |  |  | P3E15CN | P3E15CN | 860 | E15C | 00 | 2EB6210 | 200 | 200 | 400 | P |  | LND | 0 | P | E | EE37 | LUZ2 | ELE | LND |

Notes:
- P3E15BD: Expenses: 900A 125000
- HPEE15B: UDF_Actictity Name (Russia): НВ кабели (E15B), заказ на поставку/изготовление/транспортировка на площадку
- HPEE15C: UDF_Actictity Name (Russia): Кабельные уплотнения (E15C), заказ на поставку/изготовление/транспортировка на площадку
- P3E19X: Expenses: 900A 1350000
- P3E15AX: Expenses: 900A 382500
- P3E19M: Expenses: 900A 450000
- HPEE13: UDF_Actictity Name (Russia): Системы связи (E13), заказ на поставку/изготовление/транспортировка на площадку
- P3E15AM: Expenses: 900A 127500
- P3E03X: Expenses: 900A 0
- P3E03M: Expenses: 900A 0
- P3E03N: Expenses: 900A 0
- P3E15BX: Expenses: 900A 225000
- P3E15BM: Expenses: 900A 75000
- P3E14X: Expenses: 900A 0
- P3E14M: Expenses: 900A 0
- P3E14N: Expenses: 900A 0

| ID | WBS | Activity | Type | Duration | Start | Finish | Predecessors | Complete | Remaining | Total float | Free float | Calendar | Cost | Actual cost | UDF_SAVE ACTID | UDF_SAVE ACT ID | Department | Constr. Area | Pro Unit/DocCode | PMT-Area | PMT-Phase | WBS Phase | WBS Discipline | WBS Type of Work | WBS Objects | IMS | UPT | Type of Work | Inquiry/Order No | PMT-Schedule Org | PMT-Discipline | PMT-Doc. Type | PMT-Respons. | Zeigen/n. Zeigen |
| --- | --- | --- | --- | --- | --- | --- | --- | --- | --- | --- | --- | --- | --- | --- | --- | --- | --- | --- | --- | --- | --- | --- | --- | --- | --- | --- | --- | --- | --- | --- | --- | --- | --- | --- |
|  | J | **J Instrumentation** |  |  | 2008-03-27 | 2012-02-25 |  |  |  |  |  |  |  |  |  |  |  |  |  |  |  |  |  |  |  |  |  |  |  |  |  |  |  |  |
| F3110 |  | Instrumentation Procurement & Supply | level of effort | 725d | 2008-03-27 A | 2011-02-11 A | P3J02A SS, F2570 SS, P3J01A SS, P3J01AA SS, P3J02CA SS, P3J02BA SS, P3J03A SS | 100% |  |  |  |  |  |  | F3110 | F3110 | 860 | 00 | 91 | 200 | P | P | J | 0000 | LUZ2 | INS | LND |  |  |  |  |  |  |  |
| P3J02A |  | J02 Control Valves - Prepare/Issue RFQ |  | 4d | 2008-03-27 A | 2008-04-01 A | E3J0210 | 100% |  |  |  |  |  |  | P3J02A | P3J02A | 860 | 00 |  | 200 | P | P | J | PJ31 | LUZ2 | INS | LND | J02 | 2AJ3030 | 200 | 400 | DEV | LND | 0 |
| P3J02BA |  | J02B Knife Valves - Prepare/Issue RFQ |  | 4d | 2008-03-27 A | 2008-04-01 A | E3J02B10 | 100% |  |  |  |  |  |  | P3J02BA | P3J02BA | 860 | 00 |  | 200 | P | P | J | PJ31 | LUZ2 | INS | LND | J02B | 2AJ3000 | 200 | 400 | DEV | LND | 0 |
| P3J02DA |  | J02D ON/OFF Plug Valves - Prepare/Issue RFQ |  | 4d | 2008-03-27 A | 2008-04-01 A | E3J02D10 | 100% |  |  |  |  |  |  | P3J02DA | P3J02DA | 860 | 00 |  | 200 | P | P | J | PJ31 | LUZ2 | INS | LND | J02D | 2AJ3020 | 200 | 400 | DEV | LND | 0 |
| P3J01AA |  | J01A Ball Valves - Prepare/Issue RFQ |  | 4d | 2008-04-02 A | 2008-04-07 A | E3J01A10 | 100% |  |  |  |  |  |  | P3J01AA | P3J01AA | 860 | 00 |  | 200 | P | P | J | PJ31 | LUZ2 |  | LND | J01A | 2AJ2610 | 200 | 400 | DEV | LND | 0 |
| P3J02B |  | J02 Control Valves - RFQ issued | milestone | 0d | 2008-04-02 A | 2008-04-02 A | P3J02A FF | 100% |  |  |  |  | 54,687.5 | 54,687.5 | P3J02B | P3J02B | 860 | 00 |  | 200 | P | P | J | PJ31 | LUZ2 | INS | LND | J02 | 2AJ3030 | 200 | 400 | DEV | LND | 0 |
| P3J02BB |  | J02B Knife Valves - RFQ issued | milestone | 0d | 2008-04-02 A | 2008-04-02 A | P3J02BA FF | 100% |  |  |  |  | 6,612.05 | 6,612.05 | P3J02BB | P3J02BB | 860 | 00 |  | 200 | P | P | J | PJ31 | LUZ2 | INS | LND | J02B | 2AJ3000 | 200 | 400 | DEV | LND | 0 |
| P3J02DB |  | J02D ON/OFF Plug Valves - RFQ issued | milestone | 0d | 2008-04-02 A | 2008-04-02 A | P3J02DA FF | 100% |  |  |  |  | 25,157.95 | 25,157.95 | P3J02DB | P3J02DB | 860 | 00 |  | 200 | P | P | J | PJ31 | LUZ2 | INS | LND | J02D | 2AJ3020 | 200 | 400 | DEV | LND | 0 |
| P3J01A |  | J01 Ball Valves PDS - Prepare/Issue RFQ |  | 3d | 2008-04-03 A | 2008-04-07 A | E3J0110 | 100% |  |  |  |  |  |  | P3J01A | P3J01A | 860 | 00 |  | 200 | P | P | J | PJ31 | LUZ2 |  | LND | J01 | 2AJ2620 | 200 | 400 | DEV | LND | 0 |
| P3J04AA |  | J04A Coriolis Mass Flowmeter - Prepare/Issue RFQ |  | 4d | 2008-04-03 A | 2008-04-08 A | E3J04A10 | 100% |  |  |  |  |  |  | P3J04AA | P3J04AA | 860 | 00 |  | 200 | P | P | J | PJ31 | LUZ2 | INS | LND | J04A | 2JD7280 | 200 | 400 | DEV | LND | 0 |
| P3J04BA |  | J04B Vortex Flowmeter - Prepare/Issue RFQ |  | 4d | 2008-04-03 A | 2008-04-08 A | E3J04B10 | 100% |  |  |  |  |  |  | P3J04BA | P3J04BA | 860 | 00 |  | 200 | P | P | J | PJ31 | LUZ2 | INS | LND | J04B | 2JD9260 | 200 | 400 | DEV | LND | 0 |
| P3J01AB |  | J01A Ball Valves - RFQ issued | milestone | 0d | 2008-04-08 A | 2008-04-08 A | P3J01AA FF | 100% |  |  |  |  | 126,000 | 126,000 | P3J01AB | P3J01AB | 860 | 00 |  | 200 | P | P | J | PJ31 | LUZ2 |  | LND | J01A | 2AJ2610 | 200 | 400 | DEV | LND | 0 |
| P3J01B |  | J01 Ball Valves PDS - RFQ issued | milestone | 0d | 2008-04-08 A | 2008-04-08 A | P3J01A FF | 100% |  |  |  |  | 8,252.9 | 8,252.9 | P3J01B | P3J01B | 860 | 00 |  | 200 | P | P | J | PJ31 | LUZ2 | INS | LND | J01 | 2AJ2620 | 200 | 400 | DEV | LND | 0 |
| P3J04AB |  | J04A Coriolis Mass Flowmeter - RFQ issued | milestone | 0d | 2008-04-09 A | 2008-04-09 A | P3J04AA FF | 100% |  |  |  |  | 7,560.25 | 7,560.25 | P3J04AB | P3J04AB | 860 | 00 |  | 200 | P | P | J | PJ31 | LUZ2 | INS | LND | J04A | 2JD7280 | 200 | 400 | DEV | LND | 0 |
| P3J04BB |  | J04B Vortex Flowmeter - RFQ issued | milestone | 0d | 2008-04-09 A | 2008-04-09 A | P3J04BA FF | 100% |  |  |  |  | 11,563.7 | 11,563.7 | P3J04BB | P3J04BB | 860 | 00 |  | 200 | P | P | J | PJ31 | LUZ2 | INS | LND | J04B | 2JD9260 | 200 | 400 | DEV | LND | 0 |
| P3J04CA |  | J04C Orifice/Venturi T. - Prepare/Issue RFQ |  | 4d | 2008-04-16 A | 2008-04-21 A | E3J04C10 | 100% |  |  |  |  |  |  | P3J04CA | P3J04CA | 860 | 00 |  | 200 | P | P | J | PJ31 | LUZ2 | INS | LND | J04C | 2JD7320 | 200 | 400 | DEV | LND | 0 |
| P3J02AA |  | J02A PCV Valves - Prepare/Issue RFQ |  | 3d | 2008-04-17 A | 2008-04-21 A | E3J02A10 | 100% |  |  |  |  |  |  | P3J02AA | P3J02AA | 860 | 00 |  | 200 | P | P | J | PJ31 | LUZ2 | INS | LND | J02A | 2AJ2660 | 200 | 400 | DEV | LND | 0 |
| P3J04EA |  | J04E Var.Area Flow.(Rotam.) - Prepare/Issue RFQ |  | 2d | 2008-04-18 A | 2008-04-21 A | E3J04E10 | 100% |  |  |  |  |  |  | P3J04EA | P3J04EA | 860 | 00 |  | 200 | P | P | J | PJ31 | LUZ2 | INS | LND | J04E | 2JD7330 | 200 | 400 | DEV | LND | 0 |
| P3J02AB |  | J02A PCV Valves - RFQ issued | milestone | 0d | 2008-04-22 A | 2008-04-22 A | P3J02AA FF | 100% |  |  |  |  | 24,331.1 | 24,331.1 | P3J02AB | P3J02AB | 860 | 00 |  | 200 | P | P | J | PJ31 | LUZ2 | INS | LND | J02A | 2AJ2660 | 200 | 400 | DEV | LND | 0 |
| P3J02CA |  | J02C Butterfly Valves on/off - Prepare/Issue RFQ |  | 4d | 2008-04-22 A | 2008-04-25 A | E3J02C10 | 100% |  |  |  |  |  |  | P3J02CA | P3J02CA | 860 | 00 |  | 200 | P | P | J | PJ31 | LUZ2 | INS | LND | J02C | 2AJ3090 | 200 | 400 | DEV | LND | 0 |
| P3J03A |  | J03 Nuclear Level Meas. - Prepare/Issue RFQ |  | 4d | 2008-04-22 A | 2008-04-25 A | E3J0310 | 100% |  |  |  |  |  |  | P3J03A | P3J03A | 860 | 00 |  | 200 | P | P | J | PJ31 | LUZ2 | INS | LND | J03 | 2JD7540 | 200 | 400 | DEV | LND | 0 |
| P3J04CB |  | J04C Orifice/Venturi T. - RFQ issued | milestone | 0d | 2008-04-22 A | 2008-04-22 A | P3J04CA FF | 100% |  |  |  |  | 6,607.75 | 6,607.75 | P3J04CB | P3J04CB | 860 | 00 |  | 200 | P | P | J | PJ31 | LUZ2 | INS | LND | J04C | 2JD7320 | 200 | 400 | DEV | LND | 0 |
| P3J04EB |  | J04E Var.Area Flow.(Rotam.) - RFQ issued | milestone | 0d | 2008-04-22 A | 2008-04-22 A | P3J04EA FF | 100% |  |  |  |  | 16,519.55 | 16,519.55 | P3J04EB | P3J04EB | 860 | 00 |  | 200 | P | P | J | PJ31 | LUZ2 | INS | LND | J04E | 2JD7330 | 200 | 400 | DEV | LND | 0 |
| P3J05A |  | J05 MPS/CMS - Prepare/Issue RFQ |  | 5d | 2008-04-23 A | 2008-04-29 A | E3J0510 | 100% |  |  |  |  |  |  | P3J05A | P3J05A | 860 | 00 |  | 200 | P | P | J | PJ21 | LUZ2 | INS | LND | J05 | 2JD7520 | 200 | 400 | DEV | LND | 0 |
| P3J06A0 |  | J06 Safety Instr.Syst. SIS - Prepare/Issue RFQ |  | 5d | 2008-04-24 A | 2008-04-30 A | E3J0602 | 100% |  |  |  |  |  |  | P3J06A0 | P3J06A0 | 860 | 00 |  | 200 | P | P | J | PJ21 | LUZ2 | INS | LND | J06 | 2JD9220 | 200 | 400 | DEV | LND | 0 |
| P3J02CB |  | J02C Butterfly Valves on/off - RFQ issued | milestone | 0d | 2008-04-26 A | 2008-04-26 A | P3J02CA FF | 100% |  |  |  |  | 8,939.05 | 8,939.05 | P3J02CB | P3J02CB | 860 | 00 |  | 200 | P | P | J | PJ31 | LUZ2 | INS | LND | J02C | 2AJ3090 | 200 | 400 | DEV | LND | 0 |
| P3J03B |  | J03 Nuclear Level Measurement - RFQ issued | milestone | 0d | 2008-04-26 A | 2008-04-26 A | P3J03A FF | 100% |  |  |  |  | 28,080 | 28,080 | P3J03B | P3J03B | 860 | 00 |  | 200 | P | P | J | PJ31 | LUZ2 | INS | LND | J03 | 2JD7540 | 200 | 400 | DEV | LND | 0 |
| P3J05B |  | J05 MPS/CMS - RFQ issued | milestone | 0d | 2008-04-30 A | 2008-04-30 A | P3J05A FF | 100% |  |  |  |  | 65,200 | 65,200 | P3J05B | P3J05B | 860 | 00 |  | 200 | P | P | J | PJ21 | LUZ2 | INS | LND | J05 | 2JD7520 | 200 | 400 | DEV | LND | 0 |
| P3J06B |  | J06 Safety Instr.Syst. SIS - RFQ issued | milestone | 0d | 2008-05-01 A | 2008-05-01 A | P3J06A0 FF | 100% |  |  |  |  |  |  | P3J06B | P3J06B | 860 | 00 |  | 200 | P | P | J | PJ21 | LUZ2 | INS | LND | J06 | 2JD9220 | 200 | 400 | DEV | LND | 0 |
| E3J0603 |  | J06 DCS / SIS - Decision Period - PAC Selection / Yokogawa |  | 285d | 2008-05-05 A | 2009-06-25 A | P3J06B | 100% |  |  |  |  |  |  | E3J0603 | E3J0603 | 860 | 00 |  | 200 | P | P | J | PJ21 | LUZ2 | I | LND | J06 | 2JD9220 | 200 | 400 | DEV | PMT | 0 |
| P3J07A |  | J07 Analyser System - Prepare/Issue RFQ |  | 4d | 2008-05-09 A | 2008-05-15 A | E3J0710 | 100% |  |  |  |  |  |  | P3J07A | P3J07A | 860 | 00 |  | 200 | P | P | J | PJ31 | LUZ2 | INS | LND | J07 | 2JD7560 | 200 | 400 | DEV | LND | 0 |
| P3J07B |  | J07 Analyser System - RFQ issued | milestone | 0d | 2008-05-16 A | 2008-05-16 A | P3J07A FF | 100% |  |  |  |  | 143,500 | 143,500 | P3J07B | P3J07B | 860 | 00 |  | 200 | P | P | J | PJ31 | LUZ2 | INS | LND | J07 | 2JD7560 | 200 | 400 | DEV | LND | 0 |
| P3J03C |  | J03 Nuclear Level Meas. - Eval./Negotiation |  | 19d | 2008-05-19 A | 2008-06-12 A | E3J0320 FF, P3J03B | 100% |  |  |  |  |  |  | P3J03C | P3J03C | 860 | 00 |  | 200 | P | P | J | PJ32 | LUZ2 | INS | LND | J03 | 2JD7540 | 200 | 400 |  | LND | 0 |
| HPJ20 |  | Issue Engineering PO's | level of effort | 348d | 2008-06-13 A | 2009-10-30 A | P3J03L SS | 100% |  |  |  |  |  |  | HPJ20 | HPJ20 | 86B | 00 |  | 200 | E | P | J | PJ33 | LUZ2 | INS | LND |  |  | 200 | 400 | DFA | LND | L2 |
| HPJJ03 |  | Nuclear Level M.(J03) PO/Fabr./Transport to Site | level of effort | 938d | 2008-06-13 A | 2012-02-24 | P3J03L SS | 33% | 124d | 129d | 0d |  |  |  | HPJJ03 | HPJJ03 | 86B | 00 |  | 200 | E | P | J | PJ33 | LUZ2 | INS | LND |  |  | 200 | 400 | DFA | LND | L2 |
| P3J03D1 |  | J03 Nuclear Level Meas. - PO issued (ENG) | milestone | 0d | 2008-06-13 A | 2008-06-13 A | P3J03C FF, E3J0330 FF | 100% |  |  |  |  |  |  | P3J03D1 | P3J03D1 | 860 | 00 |  | 200 | P | P | J | PJ33 | LUZ2 | INS | LND | J03 | 2JD7540 | 200 | 400 |  | LND | 0 |
| P3J03L |  | J03 Nuclear Level Meas. - Lead Time/Fabrication |  | 1036d | 2008-06-13 A | 2011-04-25 A | P3J03D1 | 100% |  |  |  | TB26 - 2 - Manuf and Delivy |  |  | P3J03L | P3J03L | 860 | 00 |  | 200 | P | P | J | PJ36 | LUZ2 | INS | LND | J03 | 2JD7540 | 200 | 400 | DEL | LND | 0 |
| P3J02BC |  | J02B Knife Valves - Eval./Negotiation |  | 184d | 2008-09-11 A | 2009-06-12 A | P3J02BB, E3J02B20 SS | 100% |  |  |  |  |  |  | P3J02BC | P3J02BC | 860 | 00 |  | 200 | P | P | J | PJ32 | LUZ2 | INS | LND | J02B | 2AJ3000 | 200 | 400 |  | LND | 0 |
| P3J01AC |  | J01A Ball Valves - Eval./Negotiation |  | 226d | 2008-09-18 A | 2009-08-18 A | P3J01AB, E3J01A20 FF | 100% |  |  |  |  |  |  | P3J01AC | P3J01AC | 860 | 00 |  | 200 | P | P | J | PJ32 | LUZ2 |  | LND | J01A | 2AJ2610 | 200 | 400 |  | LND | 0 |
| P3J01C |  | J01 Ball Valves PDS - Eval./Negotiation |  | 174d | 2008-09-25 A | 2009-06-12 A | P3J01B, E3J0120 SS | 100% |  |  |  |  |  |  | P3J01C | P3J01C | 860 | 00 |  | 200 | P | P | J | PJ32 | LUZ2 | INS | LND | J01 | 2AJ2620 | 200 | 400 |  | LND | 0 |
| P3J02DC |  | J02D ON/OFF Plug Valves -Eval./Negotiation |  | 188d | 2008-09-26 A | 2009-07-03 A | P3J02DB, E3J02D20 SS | 100% |  |  |  |  |  |  | P3J02DC | P3J02DC | 860 | 00 |  | 200 | P | P | J | PJ32 | LUZ2 | INS | LND | J02D | 2AJ3020 | 200 | 400 |  | LND | 0 |
| P3J04AC |  | J04A Coriolis Mass Flowmeter - Eval./Negotiation |  | 177d | 2008-09-26 A | 2009-06-18 A | P3J04AB, E3J04A20 SS | 100% |  |  |  |  |  |  | P3J04AC | P3J04AC | 860 | 00 |  | 200 | P | P | J | PJ32 | LUZ2 | INS | LND | J04A | 2JD7280 | 200 | 400 |  | LND | 0 |
| P3J04BC |  | J04B Vortex Flowmeter - Eval./Negotiation |  | 173d | 2008-09-26 A | 2009-06-12 A | E3J04B20 FF, P3J04BB | 100% |  |  |  |  |  |  | P3J04BC | P3J04BC | 860 | 00 |  | 200 | P | P | J | PJ32 | LUZ2 | INS | LND | J04B | 2JD9260 | 200 | 400 |  | LND | 0 |
| P3J02CC |  | J02C Butterfly Valves on/off - Eval./Negotiation |  | 161d | 2008-10-01 A | 2009-05-29 A | P3J02CB, E3J02C20 SS | 100% |  |  |  |  |  |  | P3J02CC | P3J02CC | 860 | 00 |  | 200 | P | P | J | PJ32 | LUZ2 | INS | LND | J02C | 2AJ3090 | 200 | 400 |  | LND | 0 |
| P3J02C |  | J02 Control Valves - Eval./Negotiation |  | 190d | 2008-10-02 A | 2009-07-13 A | P3J02B, E3J0220 FF | 100% |  |  |  |  |  |  | P3J02C | P3J02C | 860 | 00 |  | 200 | P | P | J | PJ32 | LUZ2 | INS | LND | J02 | 2AJ3030 | 200 | 400 |  | LND | 0 |
| P3J18A |  | J18 Weighing for Vessels - Prepare/Issue RFQ |  | 4d | 2008-10-13 A | 2008-10-16 A | E3J1810 | 100% |  |  |  |  |  |  | P3J18A | P3J18A | 860 | 00 |  | 200 | P | P | J | PJ31 | LUZ2 |  | LND | J18 | J18 | 200 | 400 | DEV | LND | 0 |
| P3J18B |  | J18 Weighing for Vessels - RFQ issued | milestone | 0d | 2008-10-17 A | 2008-10-17 A | P3J18A FF | 100% |  |  |  |  | 1,683.4 | 1,683.4 | P3J18B | P3J18B | 860 | 00 |  | 200 | P | P | J | PJ31 | LUZ2 |  | LND | J18 | J18 | 200 | 400 | DEV | LND | 0 |
| P3J02BF |  | J02B Knife Valves - Bid tab Client appr. |  | 32d | 2008-10-28 A | 2008-12-12 A | E3J02B30 | 100% |  |  |  |  |  |  | P3J02BF | P3J02BF | 860 | 00 |  | 200 | P | P | J | PJ32 | LUZ2 | INS | LND | J02B | 2AJ3000 | 200 | 400 |  | PMT | 0 |
| P3J02F |  | J02 Control Valves - Bid tab Client appr. |  | 16d | 2008-11-28 A | 2008-12-19 A | E3J0230 | 100% |  |  |  |  |  |  | P3J02F | P3J02F | 860 | 00 |  | 200 | P | P | J | PJ32 | LUZ2 | INS | LND | J02 | 2AJ3030 | 200 | 400 |  | PMT | 0 |
| P3J12AA |  | J12A Radar Level M. - Prepare/Issue RFQ |  | 6d | 2008-11-28 A | 2008-12-05 A | E3J12A10 | 100% |  |  |  |  |  |  | P3J12AA | P3J12AA | 860 | 00 |  | 200 | P | P | J | PJ31 | LUZ2 | INS | LND | J12A | 2JD8440 | 200 | 400 | DEV | LND | 0 |
| P3J12AB |  | J12A Radar Level M. - RFQ issued | milestone | 0d | 2008-12-06 A | 2008-12-06 A | P3J12AA FF | 100% |  |  |  |  | 1,651.9 | 1,651.9 | P3J12AB | P3J12AB | 860 | 00 |  | 200 | P | P | J | PJ31 | LUZ2 | INS | LND | J12A | 2JD8440 | 200 | 400 | DEV | LND | 0 |
| P3J07C |  | J07 Analyser System -Eval./Negotiation |  | 260d | 2008-12-17 A | 2010-01-05 A | P3J07B, E3J0720 FF | 100% |  |  |  |  |  |  | P3J07C | P3J07C | 860 | 00 |  | 200 | P | P | J | PJ32 | LUZ2 | INS | LND | J07 | 2JD7560 | 200 | 400 |  | LND | 0 |
| P3J01F |  | J01 Ball Valves PDS - Bid tab Client appr. |  | 15d | 2008-12-22 A | 2009-01-16 A | E3J0130 | 100% |  |  |  |  |  |  | P3J01F | P3J01F | 860 | 00 |  | 200 | P | P | J | PJ32 | LUZ2 | INS | LND | J01 | 2AJ2620 | 200 | 400 |  | PMT | 0 |
| P3J06FA |  | J06F PLC Network - Prepare/Issue RFQ |  | 3d | 2009-01-09 A | 2009-01-13 A | E3J06F10 | 100% |  |  |  |  |  |  | P3J06FA | P3J06FA | 860 | 00 |  | 200 | P | P | J | PJ31 | LUZ2 | INS | LND | J06F | 2JD8450 | 200 | 400 | DEV | LND | 0 |
| P3J06FB |  | J06F PLC Network - RFQ issued | milestone | 0d | 2009-01-14 A | 2009-01-14 A | P3J06FA FF | 100% |  |  |  |  | 7,200 | 7,200 | P3J06FB | P3J06FB | 860 | 00 |  | 200 | P | P | J | PJ31 | LUZ2 | INS | LND | J06F | 2JD8450 | 200 | 400 | DEV | LND | 0 |
| P3J04CC |  | J04C Orifice/Venturi T. - Eval./Negotiation |  | 280d | 2009-01-29 A | 2010-03-10 A | E3J04C20 SS, P3J04CB | 100% |  |  |  |  |  |  | P3J04CC | P3J04CC | 860 | 00 |  | 200 | P | P | J | PJ32 | LUZ2 | INS | LND | J04C | 2JD7320 | 200 | 400 |  | LND | 0 |
| P3J02BE |  | J02B Knife Valves - Vendor Selection approval |  | 78d | 2009-02-02 A | 2009-05-26 A | P3J02BF FF | 100% |  |  |  |  |  |  | P3J02BE | P3J02BE | 860 | 00 |  | 200 | P | P | J | PJ32 | LUZ2 | INS | LND | J02B | 2AJ3000 | 200 | 400 |  | PMT | 0 |
| P3J02E |  | J02 Control Valves - Vendor Selection approval |  | 92d | 2009-02-02 A | 2009-06-16 A | P3J02F FF | 100% |  |  |  |  |  |  | P3J02E | P3J02E | 860 | 00 |  | 200 | P | P | J | PJ32 | LUZ2 | INS | LND | J02 | 2AJ3030 | 200 | 400 |  | PMT | 0 |
| P3J04IA |  | J04I Ultrasonic Flowm. - Prepare/Issue RFQ |  | 5d | 2009-02-16 A | 2009-02-20 A | E3J04I10 | 100% |  |  |  |  |  |  | P3J04IA | P3J04IA | 860 | 00 |  | 200 | P | P | J | PJ31 | LUZ2 | INS | LND | J04I | 2JD8500 | 200 | 400 | DEV | LND | 0 |
| P3J18C |  | J18 Weighing for Vessels - Eval./Negotiation |  | 299d | 2009-02-18 A | 2010-04-28 A | P3J18B, E3J1820 FF | 100% |  |  |  |  |  |  | P3J18C | P3J18C | 860 | 00 |  | 200 | P | P | J | PJ32 | LUZ2 | INS | LND | J18 | J18 | 200 | 400 |  | LND | 0 |
| P3J04IB |  | J04I Ultrasonic Flowm. - RFQ issued | milestone | 0d | 2009-02-21 A | 2009-02-21 A | P3J04IA FF | 100% |  |  |  |  | 14,867.65 | 14,867.65 | P3J04IB | P3J04IB | 860 | 00 |  | 200 | P | P | J | PJ31 | LUZ2 | INS | LND | J04I | 2JD8500 | 200 | 400 | DEV | LND | 0 |
| P3J04EC |  | J04E Var.Area Flow.(Rotam.) - Eval./Negotiation |  | 313d | 2009-02-24 A | 2010-05-26 A | P3J04EB, E3J04E20 FF | 100% |  |  |  |  |  |  | P3J04EC | P3J04EC | 860 | 00 |  | 200 | P | P | J | PJ32 | LUZ2 | INS | LND | J04E | 2JD7330 | 200 | 400 |  | LND | 0 |
| P3J01E |  | J01 Ball Valves PDS - Vendor Selection approval |  | 61d | 2009-02-25 A | 2009-05-26 A | P3J01F FF | 100% |  |  |  |  |  |  | P3J01E | P3J01E | 860 | 00 |  | 200 | P | P | J | PJ32 | LUZ2 | INS | LND | J01 | 2AJ2620 | 200 | 400 |  | PMT | 0 |
| P3J04CE |  | J04C Orifice/Venturi T. - Vendor Selection appr |  | 112d | 2009-02-25 A | 2009-08-06 A | P3J04CF FF | 100% |  |  |  |  |  |  | P3J04CE | P3J04CE | 860 | 00 |  | 200 | P | P | J | PJ32 | LUZ2 | INS | LND | J04C | 2JD7320 | 200 | 400 |  | PMT | 0 |
| P3J04CF |  | J04C Orifice/Venturi T. - Bid tab Client appr. |  | 112d | 2009-02-25 A | 2009-08-06 A | E3J04C30 | 100% |  |  |  |  |  |  | P3J04CF | P3J04CF | 860 | 00 |  | 200 | P | P | J | PJ32 | LUZ2 | INS | LND | J04C | 2JD7320 | 200 | 400 |  | PMT | 0 |
| P3J12AC |  | J12A Radar Level M. -Eval./Negotiation |  | 77d | 2009-02-26 A | 2009-06-19 A | E3J12A20 FF, P3J12AB | 100% |  |  |  |  |  |  | P3J12AC | P3J12AC | 860 | 00 |  | 200 | P | P | J | PJ32 | LUZ2 | INS | LND | J12A | 2JD8440 | 200 | 400 |  | LND | 0 |
| A1MEEJ02 |  | Inq. & Order Process Control Equipment |  | 471d | 2009-03-03 A | 2011-01-13 A | A1EJ0915 FF+80d | 100% |  |  |  |  |  |  | A1MEEJ02 | A1MEEJ02 | 860 | 00 |  | 200 | P | P | J | 0000 | LUZ2 | INS | LND |  |  |  |  |  |  |  |
| P3J02CE |  | J02C Butterfly Valves on - Vendor Selection appr |  | 57d | 2009-03-03 A | 2009-05-26 A | P3J02CF FF | 100% |  |  |  |  |  |  | P3J02CE | P3J02CE | 860 | 00 |  | 200 | P | P | J | PJ32 | LUZ2 | INS | LND | J02C | 2AJ3090 | 200 | 400 |  | PMT | 0 |
| P3J02CF |  | J02C Butterfly Valves on/ - Bid tab Client appr. |  | 14d | 2009-03-03 A | 2009-03-20 A | E3J02C30 | 100% |  |  |  |  |  |  | P3J02CF | P3J02CF | 860 | 00 |  | 200 | P | P | J | PJ32 | LUZ2 | INS | LND | J02C | 2AJ3090 | 200 | 400 |  | PMT | 0 |

Notes:
- P3J02B: Expenses: 900A 54687.5
- P3J02BB: Expenses: 900A 6612.05
- P3J02DB: Expenses: 900A 25158
- P3J01AB: Expenses: 900A 126000
- P3J01B: Expenses: 900A 8252.9
- P3J04AB: Expenses: 900A 7560.25
- P3J04BB: Expenses: 900A 11563.7
- P3J02AB: Expenses: 900A 24331.1
- P3J04CB: Expenses: 900A 6607.75
- P3J04EB: Expenses: 900A 16519.5
- P3J02CB: Expenses: 900A 8939.05
- P3J03B: Expenses: 900A 28080
- P3J05B: Expenses: 900A 65200
- P3J06B: Current Status: Scope Change => Scope Client
- P3J07B: Expenses: 900A 143500
- HPJ20: UDF_Actictity Name (Russia): Выпуск заказов на проектирование
- HPJJ03: UDF_Actictity Name (Russia): Радиоизотопный уровнемер (J03), заказ на поставку/изготовление/транспортировка на площадку
- P3J03L: P3 Activity Log Info: delivery as late as possible to install just in time
- P3J18B: Expenses: 900A 1683.4
- P3J12AB: Expenses: 900A 1651.9
- P3J06FB: Expenses: 900A 7200
- P3J04IB: Expenses: 900A 14867.6

| ID | Activity | Type | Duration | Start | Finish | Predecessors | Complete | Calendar | Cost | Actual cost | UDF_SAVE ACTID | UDF_SAVE ACT ID | Department | Type of Work | Constr. Area | Inquiry/Order No | PMT-Area | PMT-Schedule Org | PMT-Discipline | PMT-Phase | PMT-Respons. | Zeigen/n. Zeigen | WBS Phase | WBS Discipline | WBS Type of Work | WBS Objects | IMS | UPT | PMT-Doc. Type |
| --- | --- | --- | --- | --- | --- | --- | --- | --- | --- | --- | --- | --- | --- | --- | --- | --- | --- | --- | --- | --- | --- | --- | --- | --- | --- | --- | --- | --- | --- |
| P3J02DE | J02D ON/OFF Plug Valves - Vendor Selection appr |  | 70d | 2009-03-04 A | 2009-06-16 A | P3J02DF FF | 100% |  |  |  | P3J02DE | P3J02DE | 860 | J02D | 00 | 2AJ3020 | 200 | 200 | 400 | P | PMT | 0 | P | J | PJ32 | LUZ2 | INS | LND |  |
| P3J02DF | J02D ON/OFF Plug Valves - Bid tab Client appr. |  | 13d | 2009-03-04 A | 2009-03-20 A | E3J02D30 | 100% |  |  |  | P3J02DF | P3J02DF | 860 | J02D | 00 | 2AJ3020 | 200 | 200 | 400 | P | PMT | 0 | P | J | PJ32 | LUZ2 | INS | LND |  |
| P3J04AE | J04A Coriolis Mass Flowm - Vendor Selection appr |  | 50d | 2009-03-12 A | 2009-05-26 A | P3J04AF FF | 100% |  |  |  | P3J04AE | P3J04AE | 860 | J04A | 00 | 2JD7280 | 200 | 200 | 400 | P | PMT | 0 | P | J | PJ32 | LUZ2 | INS | LND |  |
| P3J04AF | J04A Coriolis Mass Flowm. - Bid tab Client appr. |  | 7d | 2009-03-12 A | 2009-03-20 A | E3J04A30 | 100% |  |  |  | P3J04AF | P3J04AF | 860 | J04A | 00 | 2JD7280 | 200 | 200 | 400 | P | PMT | 0 | P | J | PJ32 | LUZ2 | INS | LND |  |
| P3J04BE | J04B Vortex Flowmeter - Vendor Selection appr |  | 50d | 2009-03-12 A | 2009-05-26 A | P3J04AF FF | 100% |  |  |  | P3J04BE | P3J04BE | 860 | J04B | 00 | 2JD9260 | 200 | 200 | 400 | P | PMT | 0 | P | J | PJ32 | LUZ2 | INS | LND |  |
| P3J04BF | J04B Vortex Flowmeter - Bid tab Client appr. |  | 7d | 2009-03-12 A | 2009-03-20 A | E3J04B30 | 100% |  |  |  | P3J04BF | P3J04BF | 860 | J04B | 00 | 2JD9260 | 200 | 200 | 400 | P | PMT | 0 | P | J | PJ32 | LUZ2 | INS | LND |  |
| P3J12BA | J12B Magn.Lev.Gauges - Prepare/Issue RFQ |  | 4d | 2009-03-16 A | 2009-03-19 A | E3J12B10 | 100% |  |  |  | P3J12BA | P3J12BA | 860 | J12B | 00 | 2JD8470 | 200 | 200 | 400 | P | LND | 0 | P | J | PJ31 | LUZ2 | INS | LND | DEV |
| P3J12BB | J12B Magn.Lev.Gauges - RFQ issued | milestone | 0d | 2009-03-20 A | 2009-03-20 A | P3J12BA FF | 100% |  | 3,304 | 3,304 | P3J12BB | P3J12BB | 860 | J12B | 00 | 2JD8470 | 200 | 200 | 400 | P | LND | 0 | P | J | PJ31 | LUZ2 | INS | LND | DEV |
| P3J13AA | J13A Pressure Gauges - Prepare/Issue RFQ |  | 3d | 2009-03-26 A | 2009-03-30 A | E3J13A10 | 100% |  |  |  | P3J13AA | P3J13AA | 860 | J13A | 00 | 2JD8480 | 200 | 200 | 400 | P | LND | 0 | P | J | PJ31 | LUZ2 | INS | LND | DEV |
| P3J12AF | J12A Radar Level M. - Bid tab Client appr. |  | 39d | 2009-03-27 A | 2009-05-26 A | E3J12A30 | 100% |  |  |  | P3J12AF | P3J12AF | 860 | J12A | 00 | 2JD8440 | 200 | 200 | 400 | P | PMT | 0 | P | J | PJ32 | LUZ2 | INS | LND |  |
| P3J13AB | J13A Pressure Gauges - RFQ issued | milestone | 0d | 2009-03-31 A | 2009-03-31 A | P3J13AA FF | 100% |  | 3,303.9 | 3,303.9 | P3J13AB | P3J13AB | 860 | J13A | 00 | 2JD8480 | 200 | 200 | 400 | P | LND | 0 | P | J | PJ31 | LUZ2 | INS | LND | DEV |
| P3J04EE | J04E Var.Area Flow.(Rota - Vendor Selection appr |  | 90d | 2009-04-08 A | 2009-08-18 A | P3J04EF FF | 100% |  |  |  | P3J04EE | P3J04EE | 860 | J04E | 00 | 2JD7330 | 200 | 200 | 400 | P | PMT | 0 | P | J | PJ32 | LUZ2 | INS | LND |  |
| P3J04EF | J04E Var.Area Flow.(Rotam.- Bid tab Client appr. |  | 90d | 2009-04-08 A | 2009-08-18 A | E3J04E30 | 100% |  |  |  | P3J04EF | P3J04EF | 860 | J04E | 00 | 2JD7330 | 200 | 200 | 400 | P | PMT | 0 | P | J | PJ32 | LUZ2 | INS | LND |  |
| P3J13BA | J13B Pressure Transm. - Prepare/Issue RFQ |  | 3d | 2009-05-04 A | 2009-05-06 A | E3J13B10 | 100% |  |  |  | P3J13BA | P3J13BA | 860 | J13B | 00 | 2JD8690 | 200 | 200 | 400 | P | LND | 0 | P | J | PJ31 | LUZ2 | INS | LND | DEV |
| P3J13BB | J13B Pressure Transm. - RFQ issued | milestone | 0d | 2009-05-06 A | 2009-05-06 A | P3J13BA FF | 100% |  | 16,519.55 | 16,519.55 | P3J13BB | P3J13BB | 860 | J13B | 00 | 2JD8690 | 200 | 200 | 400 | P | LND | 0 | P | J | PJ31 | LUZ2 | INS | LND | DEV |
| P3J02CD1 | J02C Butterfly Valves on/off - PO issued (Engin. | milestone | 0d | 2009-05-29 A | 2009-05-29 A | P3J02CC FF, P3J02CF FF, E3J02C20 FF, P3J02CE | 100% |  |  |  | P3J02CD1 | P3J02CD1 | 860 | J02C | 00 | 2AJ3090 | 200 | 200 | 400 | P | LND | 0 | P | J | PJ33 | LUZ2 | INS | LND |  |
| A1MEEJ01 | Fabr.& Delivery Process Control Equipment |  | 300d | 2009-06-02 A | 2010-08-06 A | A1MEEJ02 SS+60d | 100% |  |  |  | A1MEEJ01 | A1MEEJ01 | 860 |  | 00 |  | 200 |  |  | P |  |  | P | J | 0000 | LUZ2 | INS | LND |  |
| P3J02BD1 | J02B Knife Valves - PO issued (Engin.) | milestone | 0d | 2009-06-09 A | 2009-06-09 A | P3J02BC FF, E3J02B20 FF, P3J02BE, P3J02BF FF | 100% |  |  |  | P3J02BD1 | P3J02BD1 | 860 | J02B | 00 | 2AJ3000 | 200 | 200 | 400 | P | LND | 0 | P | J | PJ33 | LUZ2 | INS | LND |  |
| P3J04BD1 | J04B Vortex Flowmeter - PO issued (Engin.) | milestone | 0d | 2009-06-10 A | 2009-06-10 A | P3J04BC FF, P3J04BE FF, P3J04BF FF, E3J04B20 FF | 100% |  |  |  | P3J04BD1 | P3J04BD1 | 860 | J04B | 00 | 2JD9260 | 200 | 200 | 400 | P | LND | 0 | P | J | PJ33 | LUZ2 | INS | LND |  |
| P3J01D1 | J01 Ball Valves PDS - PO issued (Engin.) | milestone | 0d | 2009-06-12 A | 2009-06-12 A | E3J0120 FF, P3J01C FF, P3J01F FF, P3J01E | 100% |  |  |  | P3J01D1 | P3J01D1 | 860 | J01 | 00 | 2AJ2620 | 200 | 200 | 400 | P | LND | 0 | P | J | PJ33 | LUZ2 | INS | LND |  |
| P3J04AD1 | J04A Coriolis Mass Flowmeter - PO issued (Engin. | milestone | 0d | 2009-06-18 A | 2009-06-18 A | P3J04AE FF, P3J04AF FF, P3J04AC FF, E3J04A20 FF | 100% |  |  |  | P3J04AD1 | P3J04AD1 | 860 | J04A | 00 | 2JD7280 | 200 | 200 | 400 | P | LND | 0 | P | J | PJ33 | LUZ2 | INS | LND |  |
| P3J01AE | J01A Ball Valves - Vendor Selection approval |  | 33d | 2009-06-24 A | 2009-08-07 A | P3J01AF FF | 100% |  |  |  | P3J01AE | P3J01AE | 860 | J01A | 00 | 2AJ2610 | 200 | 200 | 400 | P | PMT | 0 | P | J | PJ32 | LUZ2 | INS | LND |  |
| P3J01AF | J01A Ball Valves - Bid tab Client appr. |  | 33d | 2009-06-24 A | 2009-08-07 A | E3J01A30 | 100% |  |  |  | P3J01AF | P3J01AF | 860 | J01A | 00 | 2AJ2610 | 200 | 200 | 400 | P | PMT | 0 | P | J | PJ32 | LUZ2 | INS | LND |  |
| E3J0604 | J06 DCS / SIS - Change Responsibilty to LINDE Scope | milestone | 0d | 2009-06-25 A | 2009-06-25 A | E3J0603 FF | 100% |  |  |  | E3J0604 | E3J0604 | 860 | J06 | 00 | 2JD9220 | 200 | 200 | 400 | P | PMT | 0 | P | J | PJ21 | LUZ2 | I | LND | DEV |
| P3J02DD1 | J02D ON/OFF Plug Valves - PO issued (Engin.) | milestone | 0d | 2009-07-03 A | 2009-07-03 A | P3J02DF FF, P3J02DC FF, E3J02D20 FF | 100% |  |  |  | P3J02DD1 | P3J02DD1 | 860 | J02D | 00 | 2AJ3020 | 200 | 200 | 400 | P | LND | 0 | P | J | PJ33 | LUZ2 | INS | LND |  |
| P3J13A | J13 Diff.-/Press.Transm.(F/L) - Prepare/Issue RFQ |  | 3d | 2009-07-13 A | 2009-07-15 A | E3J1310 | 100% |  |  |  | P3J13A | P3J13A | 860 | J13 | 00 | 2JD8840 | 200 | 200 | 400 | P | LND | 0 | P | J | PJ31 | LUZ2 | INS | LND | DEV |
| P3J02D1 | J02 Control Valves - PO issued (Engin.) | milestone | 0d | 2009-07-13 A | 2009-07-13 A | P3J02E, P3J02F FF, E3J0220 FF, P3J02C FF | 100% |  |  |  | P3J02D1 | P3J02D1 | 860 | J02 | 00 | 2AJ3030 | 200 | 200 | 400 | P | LND | 0 | P | J | PJ33 | LUZ2 | INS | LND |  |
| P3J13B | J13 Diff.-/Press.Transm.(F/L) - RFQ issued | milestone | 0d | 2009-07-15 A | 2009-07-15 A | P3J13A FF | 100% |  | 10,737.7 | 10,737.7 | P3J13B | P3J13B | 860 | J13 | 00 | 2JD8840 | 200 | 200 | 400 | P | LND | 0 | P | J | PJ31 | LUZ2 | INS | LND | DEV |
| E3J0605 | J06 DCS / SIS - Basic Clarific. with Client (philosophy) |  | 2d | 2009-07-16 A | 2009-07-17 A | E3J0604 | 100% |  |  |  | E3J0605 | E3J0605 | 860 | J06 | 00 | 2JD9220 | 200 | 200 | 400 | P | PMT | 0 | P | J | PJ21 | LUZ2 | I | LND | DEV |
| P3J07F | J07 Analyser System - Bid tab Client appr. |  | 96d | 2009-07-17 A | 2009-11-30 A | E3J0730 | 100% |  |  |  | P3J07F | P3J07F | 860 | J07 | 00 | 2JD7560 | 200 | 200 | 400 | P | PMT | 0 | P | J | PJ32 | LUZ2 | INS | PMT |  |
| P3J13CA | J13C Pressure Switches - Prepare/Issue RFQ |  | 5d | 2009-08-14 A | 2009-08-20 A | E3J13C10 | 100% |  |  |  | P3J13CA | P3J13CA | 860 | J13C | 00 | 2JD8960 | 200 | 200 | 400 | P | LND | 0 | P | J | PJ31 | LUZ2 | INS | LND | DEV |
| P3J01AD1 | J01A Ball Valves - PO issued (Engin.) | milestone | 0d | 2009-08-14 A | 2009-08-14 A | P3J01AC FF, P3J01AF FF, P3J01AE, E3J01A20 FF | 100% |  |  |  | P3J01AD1 | P3J01AD1 | 860 | J01A | 00 | 2AJ2610 | 200 | 200 | 400 | P | LND | 0 | P | J | PJ33 | LUZ2 |  | LND |  |
| P3J13CB | J13C Pressure Switches - RFQ issued | milestone | 0d | 2009-08-20 A | 2009-08-20 A | P3J13CA FF | 100% |  | 3,303.85 | 3,303.85 | P3J13CB | P3J13CB | 860 | J13C | 00 | 2JD8960 | 200 | 200 | 400 | P | LND | 0 | P | J | PJ31 | LUZ2 | INS | LND | DEV |
| P3J04IC | J04I Ultrasonic Flowm. -Eval./Negotiation |  | 247d | 2009-09-03 A | 2010-08-26 A | E3J04I20 FF, P3J04IB | 100% |  |  |  | P3J04IC | P3J04IC | 860 | J04I | 00 | 2JD8500 | 200 | 200 | 400 | P | LND | 0 | P | J | PJ32 | LUZ2 | INS | LND |  |
| P3J13BC | J13B Pressure Transm. - Eval./Negotiation |  | 177d | 2009-09-08 A | 2010-05-25 A | P3J13BB, E3J13B20 FF | 100% |  |  |  | P3J13BC | P3J13BC | 860 | J13B | 00 | 2JD8690 | 200 | 200 | 400 | P | LND | 0 | P | J | PJ32 | LUZ2 | INS | LND |  |
| IMS-E-000220 | Vendor Data Review Main Valves | level of effort | 120d | 2009-09-14 A | 2010-03-05 A | E3J02D50, E3J02B50, E3J0150, E3J01A50, E3J02C50 | 100% |  |  |  | IMS-E-000220 | IMS-E-000220 | 860 |  | 00 |  | 200 | 200 | 400 | P | LND | 0 | P | J | PJ36 | LUZ2 | PI | IMS | DEL |
| P3J14AA | J14A Thermowell+Elements - Prepare/Issue RFQ |  | 5d | 2009-10-02 A | 2009-10-08 A | E3J14A10 | 100% |  |  |  | P3J14AA | P3J14AA | 860 | J14A | 00 | 2JD8720 | 200 | 200 | 400 | P | LND | 0 | P | J | PJ31 | LUZ2 | INS | LND | DEV |
| P3J14A | J14 Temp.Transm./Thermocouple- Prepare/Issue RFQ |  | 4d | 2009-10-05 A | 2009-10-08 A | E3J1410 | 100% |  |  |  | P3J14A | P3J14A | 860 | J14 | 00 | 2JD8710 | 200 | 200 | 400 | P | LND | 0 | P | J | PJ31 | LUZ2 | INS | LND | DEV |
| P3J14BA | J14B Temp. Gauges - Prepare/Issue RFQ |  | 4d | 2009-10-05 A | 2009-10-08 A | E3J14B10 | 100% |  |  |  | P3J14BA | P3J14BA | 860 | J14B | 00 | 2JD8700 | 200 | 200 | 400 | P | LND | 0 | P | J | PJ31 | LUZ2 | INS | LND | DEV |
| P3J14AB | J14A Thermowell+Elements - RFQ issued | milestone | 0d | 2009-10-08 A | 2009-10-08 A | P3J14AA FF | 100% |  | 14,867.65 | 14,867.65 | P3J14AB | P3J14AB | 860 | J14A | 00 | 2JD8720 | 200 | 200 | 400 | P | LND | 0 | P | J | PJ31 | LUZ2 | INS | LND | DEV |
| P3J14B | J14 Temp.Transm./Thermocouple - RFQ issued | milestone | 0d | 2009-10-08 A | 2009-10-08 A | P3J14A FF | 100% |  | 16,519.55 | 16,519.55 | P3J14B | P3J14B | 860 | J14 | 00 | 2JD8710 | 200 | 200 | 400 | P | LND | 0 | P | J | PJ31 | LUZ2 | INS | LND | DEV |
| P3J14BB | J14B Temp. Gauges - RFQ issued | milestone | 0d | 2009-10-08 A | 2009-10-08 A | P3J14BA FF | 100% |  | 825.9 | 825.9 | P3J14BB | P3J14BB | 860 | J14B | 00 | 2JD8700 | 200 | 200 | 400 | P | LND | 0 | P | J | PJ31 | LUZ2 | INS | LND | DEV |
| P3J02AC | J02A PCV Valves - Eval./Negotiation |  | 79d | 2009-10-15 A | 2010-02-09 A | P3J02AB, E3J02A20 FF | 100% |  |  |  | P3J02AC | P3J02AC | 860 | J02A | 00 | 2AJ2660 | 200 | 200 | 400 | P | LND | 0 | P | J | PJ32 | LUZ2 | INS | LND |  |
| P3J13AC | J13A Pressure Gauges - Eval./Negotiation |  | 165d | 2009-10-20 A | 2010-06-18 A | P3J13AB, E3J13A20 FF | 100% |  |  |  | P3J13AC | P3J13AC | 860 | J13A | 00 | 2JD8480 | 200 | 200 | 400 | P | LND | 0 | P | J | PJ32 | LUZ2 | INS | LND |  |
| P3J12BC | J12B Magn.Lev.Gauges -Eval./Negotiation |  | 74d | 2009-10-23 A | 2010-02-10 A | E3J12B20 FF, P3J12BB | 100% |  |  |  | P3J12BC | P3J12BC | 860 | J12B | 00 | 2JD8470 | 200 | 200 | 400 | P | LND | 0 | P | J | PJ32 | LUZ2 | INS | LND |  |
| P3J12DA | J12D Vibration Fork Level Switch - Prepare/Issue RFQ |  | 5d | 2009-10-26 A | 2009-10-30 A | E3J12D10 | 100% |  |  |  | P3J12DA | P3J12DA | 860 | J12D | 00 | 2JD9190 | 200 | 200 | 400 | P | LEI | 0 | P | J | PJ31 | LUZ2 | INS | LND | DEV |
| P3J05C | J05 MPS/CMS - Eval./Negotiation |  | 203d | 2009-10-27 A | 2010-08-18 A | E3J0520 FF, P3J05B | 100% |  |  |  | P3J05C | P3J05C | 860 | J05 | 00 | 2JD7520 | 200 | 200 | 400 | P | LND | 0 | P | J | PJ22 | LUZ2 | INS | LND |  |
| P3J06C | J06 DCS / SIS - Prepare/Issue PO (FEED - Yokogawa) |  | 34d | 2009-11-02 A | 2009-12-18 A | E3J0610 | 100% |  |  |  | P3J06C | P3J06C | 860 | J06 | 00 | 2JD9220 | 200 | 200 | 400 | P | LND | 0 | P | J | PJ21 | LUZ2 | INS | LND | DEV |
| P3J12DB | J12D Vibration Fork Level Switch - RFQ issued | milestone | 0d | 2009-11-02 A | 2009-11-02 A | P3J12DA FF | 100% |  | 1,652 | 1,652 | P3J12DB | P3J12DB | 860 | J12D | 00 | 2JD9190 | 200 | 200 | 400 | P | LEI | 0 | P | J | PJ31 | LUZ2 | INS | LND | DEV |
| P3J03D2 | J03 Nuclear Level Meas. - PO issued (Equip) | milestone | 0d | 2009-12-15 A | 2009-12-15 A | P3J03D1 FS+40d | 100% |  | 140,416 | 140,416 | P3J03D2 | P3J03D2 | 860 | J03 | 00 | 2JD7540 | 200 | 200 | 400 | P | LND | 0 | P | J | PJ33 | LUZ2 | INS | LND |  |
| P3J06B2 | J06 DCS / SIS - Preparation Bid Proposal by Yokogawa |  | 58d | 2009-12-17 A | 2010-03-12 A | P3J06B1 | 100% |  |  |  | P3J06B2 | P3J06B2 | 860 | J06 | 00 | 2JD9220 | 200 | 200 | 400 | P | LND | 0 | P | J | PJ21 | LUZ2 | INS | LND | DEV |
| P3J06D1 | J06 DCS / SIS - PO issued (FEED) | milestone | 0d | 2009-12-18 A | 2009-12-18 A | P3J06C FF | 100% |  | 336,000 | 336,000 | P3J06D1 | P3J06D1 | 860 | J06 | 00 | 2JD9220 | 200 | 200 | 400 | P | LND | 0 | P | J | PJ21 | LUZ2 | B | LND | DEV |
| P3J01D2 | J01 Ball Valves PDS - PO issued (Equip.) | milestone | 0d | 2009-12-21 A | 2009-12-21 A | P3J01D1 FF+134d, AD1860 SF, E3J0130 FF, P3J01F FF, P3J01C FF, P3J01E | 100% |  | 41,264.5 | 41,264.5 | P3J01D2 | P3J01D2 | 860 | J01 | 00 | 2AJ2620 | 200 | 200 | 400 | P | LND | 0 | P | J | PJ33 | LUZ2 | INS | LND |  |
| HPJ30 | Issue Equipment PO's | level of effort | 218d | 2009-12-22 A | 2010-11-02 A | P3J01L SS, P3J01AL SS, P3J07L SS | 100% |  |  |  | HPJ30 | HPJ30 | 86B |  | 00 |  | 200 | 200 | 400 | E | LND | L2 | P | J | PJ33 | LUZ2 | INS | LND | DFA |
| HPJJ01 | Ball Valves PDS (J01) PO/Fabr./Transport to Site | level of effort | 348d | 2009-12-22 A | 2011-05-06 A | P3J01L SS | 100% |  |  |  | HPJJ01 | HPJJ01 | 86B |  | 00 |  | 200 | 200 | 400 | E | LND | L2 | P | J | PJ33 | LUZ2 | INS | LND | DFA |
| P3J01L | J01 Ball Valves PDS - Lead Time/Fabrication |  | 399d | 2009-12-22 A | 2011-01-31 A | P3J01D2 | 100% | TB26 - 2 - Manuf and Delivy |  |  | P3J01L | P3J01L | 860 | J01 | 00 | 2AJ2620 | 200 | 200 | 400 | P | LND | 0 | P | J | PJ36 | LUZ2 | INS | LND | DEL |
| P3J12DC | J12D Vibration Fork Level Switch -Eval./Negotiation |  | 226d | 2010-01-04 A | 2010-11-22 A | P3J12DB, E3J12D20 FF, P3J12DB2 FF | 100% |  |  |  | P3J12DC | P3J12DC | 860 | J12D | 00 | 2JD9190 | 200 | 200 | 400 | P | LEI | 0 | P | J | PJ32 | LUZ2 | INS | LND |  |
| P3J13C | J13 Diff.-/Press.Transm.(F/L) - Eval./Negotiation |  | 98d | 2010-01-04 A | 2010-05-25 A | P3J13B, E3J1320 FF | 100% |  |  |  | P3J13C | P3J13C | 860 | J13 | 00 | 2JD8840 | 200 | 200 | 400 | P | LND | 0 | P | J | PJ32 | LUZ2 | INS | LND |  |
| P3J14AC | J14A Thermowell+Elements - Eval./Negotiation |  | 152d | 2010-01-04 A | 2010-08-09 A | E3J14A20 FF, P3J14AB | 100% |  |  |  | P3J14AC | P3J14AC | 860 | J14A | 00 | 2JD8720 | 200 | 200 | 400 | P | LND | 0 | P | J | PJ32 | LUZ2 | INS | LND |  |
| P3J14BC | J14B Temp. Gauges - Eval./Negotiation |  | 88d | 2010-01-04 A | 2010-05-07 A | E3J14B20 FF, P3J14BB | 100% |  |  |  | P3J14BC | P3J14BC | 860 | J14B | 00 | 2JD8700 | 200 | 200 | 400 | P | LND | 0 | P | J | PJ32 | LUZ2 | INS | LND |  |
| P3J14C | J14 Temp.Transm./Thermocouple- Eval./Negotiation |  | 96d | 2010-01-04 A | 2010-05-20 A | P3J14B, E3J1420 FF | 100% |  |  |  | P3J14C | P3J14C | 860 | J14 | 00 | 2JD8710 | 200 | 200 | 400 | P | LND | 0 | P | J | PJ32 | LUZ2 | INS | LND |  |
| P3J13CC | J13C Pressure Switches - Eval./Negotiation |  | 109d | 2010-01-05 A | 2010-06-10 A | E3J13C20 FF, P3J13CB | 100% |  |  |  | P3J13CC | P3J13CC | 860 | J13C | 00 | 2JD8960 | 200 | 200 | 400 | P | LND | 0 | P | J | PJ32 | LUZ2 | INS | LND |  |
| P3J07D | J07 Analyser System - PO issued | milestone | 0d | 2010-01-05 A | 2010-01-05 A | E3J0730 FF, P3J07C FF, P3J07F FF | 100% |  | 717,500 | 717,500 | P3J07D | P3J07D | 860 | J07 | 00 | 2JD7560 | 200 | 200 | 400 | P | LND | 0 | P | J | PJ33 | LUZ2 | INS | LND |  |
| P3J12BF | J12B Magn.Lev.Gauges - Bid tab Client appr. |  | 5d | 2010-01-06 A | 2010-01-12 A | E3J12B30 | 100% |  |  |  | P3J12BF | P3J12BF | 860 | J12B | 00 | 2JD8470 | 200 | 200 | 400 | P | PMT | 0 | P | J | PJ32 | LUZ2 | INS | PMT |  |
| P3J07L | J07 Analyser System - Lead Time/Fabrication |  | 488d | 2010-01-09 A | 2011-05-16 A | P3J07D | 100% | TB26 - 2 - Manuf and Delivy |  |  | P3J07L | P3J07L | 860 | J07 | 00 | 2JD7560 | 200 | 200 | 400 | P | LND | 0 | P | J | PJ36 | LUZ2 | INS | LND | DEL |
| HPJJ07 | Analyser Syst. (J07) PO/Fabr./Transport to Site | level of effort | 387d | 2010-01-11 A | 2011-07-14 A | P3J07L SS | 100% |  |  |  | HPJJ07 | HPJJ07 | 86B |  | 00 |  | 200 | 200 | 400 | E | LND | L2 | P | J | PJ33 | LUZ2 | INS | LND | DFA |
| P3J04BD2 | J04B Vortex Flowmeter - PO issued (Equip.) | milestone | 0d | 2010-01-11 A | 2010-01-11 A | E3J04B30 FF, P3J04BF FF, P3J04BC FF | 100% |  | 57,818.5 | 57,818.5 | P3J04BD2 | P3J04BD2 | 860 | J04B | 00 | 2JD9260 | 200 | 200 | 400 | P | LND | 0 | P | J | PJ33 | LUZ2 | INS | LND |  |
| HPJJ04B | Vortex Flowm. (J04B) PO/Fabr./Transport to Site | level of effort | 362d | 2010-01-12 A | 2011-06-10 A | P3J04BL SS | 100% |  |  |  | HPJJ04B | HPJJ04B | 86B |  | 00 |  | 200 | 200 | 400 | E | LND | L2 | P | J | PJ33 | LUZ2 | INS | LND | DFA |
| P3J04BL | J04B Vortex Flowmeter - Lead Time/Fabrication |  | 271d | 2010-01-12 A | 2010-10-10 A | P3J04BD1, P3J04BD2 | 100% | TB26 - 2 - Manuf and Delivy |  |  | P3J04BL | P3J04BL | 860 | J04B | 00 | 2JD9260 | 200 | 200 | 400 | P | LND | 0 | P | J | PJ36 | LUZ2 | INS | LND | DEL |
| P3J06C1 | J06 DCS / SIS - Contract Preparation / Negotiations / LOI Issue |  | 57d | 2010-01-13 A | 2010-04-01 A | P3J06B1 FS+15d, P3J06B2 FF+4d, E3J0635 | 100% |  |  |  | P3J06C1 | P3J06C1 | 860 | J06 | 00 | 2JD9220 | 200 | 200 | 400 | P | LND | 0 | P | J | PJ21 | LUZ2 | INS | LND | DEV |

Notes:
- P3J12BB: Expenses: 900A 3304
- P3J13AB: Expenses: 900A 3303.9
- P3J13BB: Expenses: 900A 16519.5
- P3J13B: Expenses: 900A 10737.7
- P3J13CB: Expenses: 900A 3303.85
- P3J14AB: Expenses: 900A 14867.6
- P3J14B: Expenses: 900A 16519.5
- P3J14BB: Expenses: 900A 825.9
- P3J12DB: Expenses: 900A 1652
- P3J03D2: Expenses: 900A 140416
- P3J06D1: Expenses: 900A 336000
- P3J01D2: Expenses: 900A 41264.5
- HPJ30: UDF_Actictity Name (Russia): Выпуск заказов на поставку оборудования
- HPJJ01: UDF_Actictity Name (Russia): Шаровые клапаны PDS (J01), заказ на поставку/изготовление/транспортировка на площадку
- P3J07D: Expenses: 900A 717500
- HPJJ07: UDF_Actictity Name (Russia): Система анализаторов (J07), заказ на поставку/изготовление/транспортировка на площадку
- P3J04BD2: Expenses: 900A 57818.5
- HPJJ04B: UDF_Actictity Name (Russia): Расходомер вихревого типа (J04B), заказ на поставку/изготовление/транспортировка на площадку

| ID | Activity | Type | Duration | Start | Finish | Predecessors | Complete | Remaining | Total float | Free float | Calendar | Cost | Actual cost | UDF_SAVE ACTID | UDF_SAVE ACT ID | Department | Type of Work | Constr. Area | Inquiry/Order No | PMT-Area | PMT-Schedule Org | PMT-Discipline | PMT-Phase | PMT-Respons. | Zeigen/n. Zeigen | WBS Phase | WBS Discipline | WBS Type of Work | WBS Objects | IMS | UPT | PMT-Doc. Type |
| --- | --- | --- | --- | --- | --- | --- | --- | --- | --- | --- | --- | --- | --- | --- | --- | --- | --- | --- | --- | --- | --- | --- | --- | --- | --- | --- | --- | --- | --- | --- | --- | --- |
| P3J18F | J18 Weighing for Vessels - Bid tab Client appr. |  | 5d | 2010-01-18 A | 2010-01-22 A | E3J1830 | 100% |  |  |  |  |  |  | P3J18F | P3J18F | 860 | J18 | 00 | J18 | 200 | 200 | 400 | P | PMT | 0 | P | J | PJ52 | LUZ2 | INS | PMT |  |
| P3J04AD2 | J04A Coriolis Mass Flowmeter - PO issued (Equip. | milestone | 0d | 2010-01-21 A | 2010-01-21 A | HPJ30 FF, P3J04AD1 | 100% |  |  |  |  | 37,801.25 | 37,801.25 | P3J04AD2 | P3J04AD2 | 860 | J04A | 00 | 2JD7280 | 200 | 200 | 400 | P | LND | 0 | P | J | PJ33 | LUZ2 | INS | LND |  |
| HPJJ04A | Coriolis Flowm.(J04A) PO/Fabr./Transport to Site | level of effort | 354d | 2010-01-22 A | 2011-06-10 A | P3J04AL SS | 100% |  |  |  |  |  |  | HPJJ04A | HPJJ04A | 86B |  | 00 |  | 200 | 200 | 400 | E | LND | L2 | P | J | PJ33 | LUZ2 | INS | LND | DFA |
| P3J04AL | J04A Coriolis Mass Flowm. -Lead Time/Fabrication |  | 255d | 2010-01-22 A | 2010-10-04 A | P3J04AD2, P3J04AD1 | 100% |  |  |  | TB26 - 2 - Manuf and Delivy |  |  | P3J04AL | P3J04AL | 860 | J04A | 00 | 2JD7280 | 200 | 200 | 400 | P | LND | 0 | P | J | PJ36 | LUZ2 | INS | LND | DEL |
| P3J06FC | J06F PLC Network -Eval./Negotiation |  | 190d | 2010-01-25 A | 2010-10-21 A | E3J06F20 FF+10d, P3J06FB | 100% |  |  |  |  |  |  | P3J06FC | P3J06FC | 860 | J06F | 00 | 2JD8450 | 200 | 200 | 400 | P | LND | 0 | P | J | PJ32 | LUZ2 | INS | LND |  |
| P3J02DD2 | J02D ON/OFF Plug Valves - PO issued (Equip.) | milestone | 0d | 2010-01-26 A | 2010-01-26 A | P3J02DD1 FF+140d, E3J02D30 FF, P3J02DE, P3J02DF FF, P3J02DC FF | 100% |  |  |  |  | 125,789.75 | 125,789.75 | P3J02DD2 | P3J02DD2 | 860 | J02D | 00 | 2AJ3020 | 200 | 200 | 400 | P | LND | 0 | P | J | PJ33 | LUZ2 | INS | LND |  |
| HPJJ02D | Plug Valves (J02D) PO/Fabr./Transport to Site | level of effort | 365d | 2010-01-27 A | 2011-06-30 A | P3J02DL SS | 100% |  |  |  |  |  |  | HPJJ02D | HPJJ02D | 86B |  | 00 |  | 200 | 200 | 400 | E | LND | L2 | P | J | PJ33 | LUZ2 | INS | LND | DFA |
| P3J02DL | J02D ON/OFF Plug Valves - Lead Time/Fabrication |  | 307d | 2010-01-27 A | 2010-11-30 A | P3J02DD1, P3J02DD2 | 100% |  |  |  | TB26 - 2 - Manuf and Delivy |  |  | P3J02DL | P3J02DL | 860 | J02D | 00 | 2AJ3020 | 200 | 200 | 400 | P | LND | 0 | P | J | PJ36 | LUZ2 | INS | LND | DEL |
| P3J02AF | J02A PCV Valves - Bid tab Client appr. |  | 5d | 2010-01-28 A | 2010-02-03 A | E3J02A30 | 100% |  |  |  |  |  |  | P3J02AF | P3J02AF | 860 | J02A | 00 | 2AJ2660 | 200 | 200 | 400 | P | PMT | 0 | P | J | PJ32 | LUZ2 | INS | PMT |  |
| HPJJ12B | Magn. Level G. (J12B) PO/Fabr./Transport to Site | level of effort | 291d | 2010-02-09 A | 2011-03-31 A | P3J12BL SS | 100% |  |  |  |  |  |  | HPJJ12B | HPJJ12B | 86B |  | 00 |  | 200 | 200 | 400 | E | LND | L2 | P | J | PJ33 | LUZ2 | INS | LND | DFA |
| P3J12BL | J12B Magn.Lev.Gauges - Lead Time/Fab. |  | 311d | 2010-02-09 A | 2010-12-17 A | P3J12BD | 100% |  |  |  | TB26 - 2 - Manuf and Delivy |  |  | P3J12BL | P3J12BL | 860 | J12B | 00 | 2JD8470 | 200 | 200 | 400 | P | LND | 0 | P | J | PJ36 | LUZ2 | INS | LND | DEL |
| P3J02AD | J02A PCV Valves - PO issued | milestone | 0d | 2010-02-09 A | 2010-02-09 A | P3J02AC, P3J02AF | 100% |  |  |  |  | 121,655 | 121,655 | P3J02AD | P3J02AD | 860 | J02A | 00 | 2AJ2660 | 200 | 200 | 400 | P | LND | 0 | P | J | PJ33 | LUZ2 | INS | LND |  |
| HPJJ02A | PCV Valves (J02A) PO/Fabr./Transport to Site | level of effort | 341d | 2010-02-10 A | 2011-06-10 A | P3J02AL SS | 100% |  |  |  |  |  |  | HPJJ02A | HPJJ02A | 86B |  | 00 |  | 200 | 200 | 400 | E | LND | L2 | P | J | PJ33 | LUZ2 | INS | LND | DFA |
| P3J02AL | J02A PCV Valves - Lead Time/Fabrication |  | 250d | 2010-02-10 A | 2010-10-18 A | P3J02AD | 100% |  |  |  | TB26 - 2 - Manuf and Delivy |  |  | P3J02AL | P3J02AL | 860 | J02A | 00 | 2AJ2660 | 200 | 200 | 400 | P | LND | 0 | P | J | PJ36 | LUZ2 | INS | LND | DEL |
| P3J12BD | J12B Magn.Lev.Gauges - PO issued | milestone | 0d | 2010-02-10 A | 2010-02-10 A | P3J12BF FF, P3J12BC FF, E3J12B30 FF | 100% |  |  |  |  | 16,520 | 16,520 | P3J12BD | P3J12BD | 860 | J12B | 00 | 2JD8470 | 200 | 200 | 400 | P | LND | 0 | P | J | PJ33 | LUZ2 | INS | LND |  |
| P3J01AD2 | J01A Ball Valves - PO issued (Equip.) | milestone | 0d | 2010-02-16 A | 2010-02-16 A | P3J01AC FF, E3J01A30 FF, P3J01AF FF, P3J01AE, AD1860 SF, P3J01AD1 FF+127d | 100% |  |  |  |  | 630,000 | 630,000 | P3J01AD2 | P3J01AD2 | 860 | J01A | 00 | 2AJ2610 | 200 | 200 | 400 | P | LND | 0 | P | J | PJ33 | LUZ2 | INS | LND |  |
| HPJJ01A | Ball Valves (J01A) PO/Fabr./Transport to Site | level of effort | 311d | 2010-02-17 A | 2011-05-06 A | P3J01AL SS | 100% |  |  |  |  |  |  | HPJJ01A | HPJJ01A | 86B |  | 00 |  | 200 | 200 | 400 | E | LND | L2 | P | J | PJ33 | LUZ2 | INS | LND | DFA |
| P3J01AL | J01A Ball Valves - Lead Time/Fabrication |  | 345d | 2010-02-17 A | 2011-01-31 A | P3J01AD1, P3J01AD2 | 100% |  |  |  | TB26 - 2 - Manuf and Delivy |  |  | P3J01AL | P3J01AL | 860 | J01A | 00 | 2AJ2610 | 200 | 200 | 400 | P | LND | 0 | P | J | PJ36 | LUZ2 | INS | LND | DEL |
| P3J02CD2 | J02C Butterfly Valves on/off - PO issued (Equip. | milestone | 0d | 2010-03-09 A | 2010-03-09 A | P3J02CF FF, E3J02C30 FF, P3J02CC FF, P3J02CE, P3J02CD1 FF+195d | 100% |  |  |  |  | 44,695.25 | 44,695.25 | P3J02CD2 | P3J02CD2 | 860 | J02C | 00 | 2AJ3090 | 200 | 200 | 400 | P | LND | 0 | P | J | PJ33 | LUZ2 | INS | LND |  |
| P3J15A | J15 Winterization Enclosures - Prepare/Issue RFQ |  | 4d | 2010-03-10 A | 2010-03-15 A | E3J1510 | 100% |  |  |  |  |  |  | P3J15A | P3J15A | 860 | J15 | 00 | 2JD9450 | 200 | 200 | 400 | P | LEI | 0 | P | J | PJ31 | LUZ2 | INS | LND | DEV |
| HPJJ02C | Butterfly Valv.(J02C) PO/Fabr./Transport to Site | level of effort | 296d | 2010-03-10 A | 2011-05-06 A | P3J02CL SS | 100% |  |  |  |  |  |  | HPJJ02C | HPJJ02C | 86B |  | 00 |  | 200 | 200 | 400 | E | LND | L2 | P | J | PJ33 | LUZ2 | INS | LND | DFA |
| P3J02CL | J02C Butterfly Valves on/off - Lead Time/Fabric. |  | 349d | 2010-03-10 A | 2011-02-25 A | P3J02CD2, P3J02CD1 | 100% |  |  |  | TB26 - 2 - Manuf and Delivy |  |  | P3J02CL | P3J02CL | 860 | J02C | 00 | 2AJ3090 | 200 | 200 | 400 | P | LND | 0 | P | J | PJ36 | LUZ2 | INS | LND | DEL |
| P3J04CD | J04C Orifice/Venturi T. - PO issued | milestone | 0d | 2010-03-10 A | 2010-03-10 A | P3J04CF, P3J04CC FF, P3J04CE | 100% |  |  |  |  | 33,039 | 33,039 | P3J04CD | P3J04CD | 860 | J04C | 00 | 2JD7320 | 200 | 200 | 400 | P | LND | 0 | P | J | PJ33 | LUZ2 | INS | LND |  |
| HPJJ04C | Orifices/Vent. (J04C) PO/Fabr./Transport to Site | level of effort | 312d | 2010-03-11 A | 2011-05-31 A | P3J04CL SS | 100% |  |  |  |  |  |  | HPJJ04C | HPJJ04C | 86B |  | 00 |  | 200 | 200 | 400 | E | LND | L2 | P | J | PJ33 | LUZ2 | INS | LND | DFA |
| P3J04CL | J04C Orifice/Venturi T. - Lead Time/Fabrication |  | 218d | 2010-03-11 A | 2010-10-15 A | P3J04CD | 100% |  |  |  | TB26 - 2 - Manuf and Delivy |  |  | P3J04CL | P3J04CL | 860 | J04C | 00 | 2JD7320 | 200 | 200 | 400 | P | LND | 0 | P | J | PJ36 | LUZ2 | INS | LND | DEL |
| P3J15B | J15 Winterization Enclosures - RFQ issued | milestone | 0d | 2010-03-15 A | 2010-03-15 A | P3J15A FF | 100% |  |  |  |  |  |  | P3J15B | P3J15B | 860 | J15 | 00 | 2JD9450 | 200 | 200 | 400 | P | LEI | 0 | P | J | PJ31 | LUZ2 | INS | LND | DEV |
| P3J02BD2 | J02B Knife Valves - PO issued (Equip.) | milestone | 0d | 2010-03-15 A | 2010-03-15 A | P3J02BC FF, P3J02BE, P3J02BF FF, E3J02B30 FF | 100% |  |  |  |  | 33,060.25 | 33,060.25 | P3J02BD2 | P3J02BD2 | 860 | J02B | 00 | 2AJ3000 | 200 | 200 | 400 | P | LND | 0 | P | J | PJ33 | LUZ2 | INS | LND |  |
| HPJJ02B | Knife Valves (J02B) PO/Fabr./Transport to Site | level of effort | 408d | 2010-03-16 A | 2011-10-18 | P3J02BL SS |  | 33d | -67d | 0d |  |  |  | HPJJ02B | HPJJ02B | 86B |  | 00 |  | 200 | 200 | 400 | E | LND | L2 | P | J | PJ33 | LUZ2 | INS | LND | DFA |
| P3J02BL | J02B Knife Valves - Lead Time/Fabrication |  | 318d | 2010-03-16 A | 2011-01-31 A | P3J02BD2, P3J02BD1 | 100% |  |  |  | TB26 - 2 - Manuf and Delivy |  |  | P3J02BL | P3J02BL | 860 | J02B | 00 | 2AJ3000 | 200 | 200 | 400 | P | LND | 0 | P | J | PJ36 | LUZ2 | INS | LND | DEL |
| P3J13BF | J13B Pressure Transm. - Bid tab Client appr. |  | 5d | 2010-03-25 A | 2010-03-31 A | E3J13B30 | 100% |  |  |  |  |  |  | P3J13BF | P3J13BF | 860 | J13B | 00 | 2JD8690 | 200 | 200 | 400 | P | PMT | 0 | P | J | PJ32 | LUZ2 | INS | PMT |  |
| P3J14BF | J14B Temp. Gauges - Bid tab Client appr. |  | 5d | 2010-03-29 A | 2010-04-06 A | E3J14B30 | 100% |  |  |  |  |  |  | P3J14BF | P3J14BF | 860 | J14B | 00 | 2JD8700 | 200 | 200 | 400 | P | PMT | 0 | P | J | PJ32 | LUZ2 | INS | PMT |  |
| P3J06D2 | J06 DCS / SIS - PO / LOI issued | milestone | 0d | 2010-04-01 A | 2010-04-01 A | P3J06C1 FF, E3J0608 | 100% |  |  |  |  | 1,680,000 | 1,680,000 | P3J06D2 | P3J06D2 | 860 | J06 | 00 | 2JD9220 | 200 | 200 | 400 | P | LND | 0 | P | J | PJ23 | LUZ2 | B | LND |  |
| P3J06L | J06 DCS / SIS - Lead Time/Fabrication |  | 412d | 2010-04-02 A | 2011-05-23 A | P3J06D3 FF, P3J06D2 | 100% |  |  |  | TB26 - 2 - Manuf and Delivy |  |  | P3J06L | P3J06L | 860 | J06 | 00 | 2JD9220 | 200 | 200 | 400 | P | LND | 0 | P | J | PJ26 | LUZ2 | INS | LND | DEL |
| P3J07AA | J07A Sample Boards - Prepare/Issue RFQ |  | 6d | 2010-04-07 A | 2010-04-14 A | E3J07A10 | 100% |  |  |  |  |  |  | P3J07AA | P3J07AA | 860 | J07A | 00 | 2JD9480 | 200 | 200 | 400 | P | LND | 0 | P | J | PJ31 | LUZ2 | INS | LND | DEV |
| P3J13F | J13 Diff.-/Press.Transm.(F/L) - Bid tab Client appr. |  | 5d | 2010-04-12 A | 2010-04-16 A | E3J1330 | 100% |  |  |  |  |  |  | P3J13F | P3J13F | 860 | J13 | 00 | 2JD8840 | 200 | 200 | 400 | P | PMT | 0 | P | J | PJ32 | LUZ2 | INS | PMT |  |
| P3J15C | J15 Winterization Enclosures - Eval./Negotiation |  | 106d | 2010-04-12 A | 2010-09-08 A | E3J1520 FF, P3J15B | 100% |  |  |  |  |  |  | P3J15C | P3J15C | 860 | J15 | 00 | 2JD9450 | 200 | 200 | 400 | P | LEI | 0 | P | J | PJ32 | LUZ2 | INS | LND |  |
| P3J07AB | J07A Sample Boards - RFQ issued | milestone | 0d | 2010-04-14 A | 2010-04-14 A | P3J07AA FF | 100% |  |  |  |  | 4,130.1 | 4,130.1 | P3J07AB | P3J07AB | 860 | J07A | 00 | 2JD9480 | 200 | 200 | 400 | P | LND | 0 | P | J | PJ31 | LUZ2 | INS | LND | DEV |
| P3J18D | J18 Weighing for Vessels - PO issued (Equip.) | milestone | 0d | 2010-04-28 A | 2010-04-28 A | P3J18F FF, P3J18C FF | 100% |  |  |  |  | 8,417 | 8,417 | P3J18D | P3J18D | 860 | J18 | 00 | J18 | 200 | 200 | 400 | P | LND | 0 | P | J | PJ33 | LUZ2 | INS | LND |  |
| HPJJ18 | Weighing Syst. (J18) PO/Fabr./Transport to Site | level of effort | 149d | 2010-04-30 A | 2010-11-29 A | P3J18L SS | 100% |  |  |  |  |  |  | HPJJ18 | HPJJ18 | 86B |  | 00 |  | 200 | 200 | 400 | E | LND | L2 | P | J | PJ33 | LUZ2 | INS | LND | DFA |
| P3J18L | J18 Weighing for Vessels - Lead Time/Fabrication |  | 153d | 2010-04-30 A | 2010-09-30 A | P3J18D | 100% |  |  |  | TB26 - 2 - Manuf and Delivy |  |  | P3J18L | P3J18L | 860 | J18 | 00 | J18 | 200 | 200 | 400 | P | LND | 0 | P | J | PJ36 | LUZ2 | INS | LND | DEL |
| P3J07CA | J07C Local Indicat. Panels - Prepare/Issue RFQ |  | 5d | 2010-05-07 A | 2010-05-14 A | E3J07C10 | 100% |  |  |  |  |  |  | P3J07CA | P3J07CA | 860 | J07C | 00 | 2JD9500 | 200 | 200 | 400 | P | LEI | 0 | P | J | PJ31 | LUZ2 | INS | LND | DEV |
| P3J14F | J14 Temp.Transm./Thermoco - Bid tab Client appr. |  | 5d | 2010-05-07 A | 2010-05-14 A | E3J1430 | 100% |  |  |  |  |  |  | P3J14F | P3J14F | 860 | J14 | 00 | 2JD8710 | 200 | 200 | 400 | P | PMT | 0 | P | J | PJ32 | LUZ2 | INS | PMT |  |
| P3J14BD | J14B Temp. Gauges - PO issued | milestone | 0d | 2010-05-07 A | 2010-05-07 A | P3J14BF FF, E3J14B30 FF, P3J14BC FF | 100% |  |  |  |  | 4,129.5 | 4,129.5 | P3J14BD | P3J14BD | 860 | J14B | 00 | 2JD8700 | 200 | 200 | 400 | P | LND | 0 | P | J | PJ33 | LUZ2 | INS | LND |  |
| P3J14BL | J14B Temp. Gauges - Lead Time/Fabrication |  | 266d | 2010-05-08 A | 2011-01-31 A | F3110 FF, P3J14BD | 100% |  |  |  | TB26 - 2 - Manuf and Delivy |  |  | P3J14BL | P3J14BL | 860 | J14B | 00 | 2JD8700 | 200 | 200 | 400 | P | LND | 0 | P | J | PJ36 | LUZ2 | INS | LND | DEL |
| HPJJ14B | Temp. Gauges (J14B) PO/Fabr./Transport to Site | level of effort | 327d | 2010-05-10 A | 2011-08-16 A | P3J14BL SS | 100% |  |  |  |  |  |  | HPJJ14B | HPJJ14B | 86B |  | 00 |  | 200 | 200 | 400 | E | LND | L2 | P | J | PJ33 | LUZ2 | INS | LND | DFA |
| P3J06EA | J06E Junction Boxes - Prepare/Issue RFQ |  | 5d | 2010-05-10 A | 2010-05-17 A | E3J06E10 | 100% |  |  |  |  |  |  | P3J06EA | P3J06EA | 860 | J06E | 00 | 2JD9620 | 200 | 200 | 400 | P | LND | 0 | P | J | PJ31 | LUZ2 | INS | LND | DEV |
| P3J07AC | J07A Sample Boards -Eval./Negotiation |  | 126d | 2010-05-10 A | 2010-11-03 A | E3J07A20 FF, P3J07AB | 100% |  |  |  |  |  |  | P3J07AC | P3J07AC | 860 | J07A | 00 | 2JD9480 | 200 | 200 | 400 | P | LND | 0 | P | J | PJ32 | LUZ2 | INS | LND |  |
| P3J05F | J05 MPS/CMS - Bid tab Client appr. |  | 67d | 2010-05-14 A | 2010-08-17 A | E3J0530 | 100% |  |  |  |  |  |  | P3J05F | P3J05F | 860 | J05 | 00 | 2JD7520 | 200 | 200 | 400 | P | PMT | 0 | P | J | PJ22 | LUZ2 | INS | PMT |  |
| P3J07CB | J07C Local Indicat. Panels - RFQ issued | milestone | 0d | 2010-05-14 A | 2010-05-14 A | P3J07CA FF | 100% |  |  |  |  |  |  | P3J07CB | P3J07CB | 860 | J07C | 00 | 2JD9500 | 200 | 200 | 400 | P | LEI | 0 | P | J | PJ31 | LUZ2 | INS | LND | DEV |
| P3J06EB | J06E Junction Boxes - RFQ issued | milestone | 0d | 2010-05-17 A | 2010-05-17 A | P3J06EA FF | 100% |  |  |  |  |  |  | P3J06EB | P3J06EB | 860 | J06E | 00 | 2JD9620 | 200 | 200 | 400 | P | LND | 0 | P | J | PJ31 | LUZ2 | INS | LND | DEV |
| P3J14D | J14 Temp.Transm./Thermocouple - PO issued | milestone | 0d | 2010-05-20 A | 2010-05-20 A | E3J1430 FF, P3J14F FF, P3J14C FF | 100% |  |  |  |  | 82,597.75 | 82,597.75 | P3J14D | P3J14D | 860 | J14 | 00 | 2JD8710 | 200 | 200 | 400 | P | LND | 0 | P | J | PJ33 | LUZ2 | INS | LND |  |
| HPJJ14 | Temp.Transm. (J14) PO/Fabr./Transport to Site | level of effort | 319d | 2010-05-21 A | 2011-08-16 A | P3J14L SS, P3J14AL SS | 100% |  |  |  |  |  |  | HPJJ14 | HPJJ14 | 86B |  | 00 |  | 200 | 200 | 400 | E | LND | L2 | P | J | PJ33 | LUZ2 | INS | LND | DFA |
| P3J14L | J14 Temp.Transm./Thermoc - Lead Time/Fabrication |  | 184d | 2010-05-21 A | 2010-11-20 A | P3J14D, F3110 FF | 100% |  |  |  | TB26 - 2 - Manuf and Delivy |  |  | P3J14L | P3J14L | 860 | J14 | 00 | 2JD8710 | 200 | 200 | 400 | P | LND | 0 | P | J | PJ36 | LUZ2 | INS | LND | DEL |
| P3J13BD | J13B Pressure Transm. - PO issued | milestone | 0d | 2010-05-25 A | 2010-05-25 A | P3J13BF FF+10d, P3J13BC FF, E3J13B30 FF | 100% |  |  |  |  | 82,597.75 | 82,597.75 | P3J13BD | P3J13BD | 860 | J13B | 00 | 2JD8690 | 200 | 200 | 400 | P | LND | 0 | P | J | PJ33 | LUZ2 | INS | LND |  |
| P3J13D | J13 Diff.-/Press.Transm.(F/L) - PO issued | milestone | 0d | 2010-05-25 A | 2010-05-25 A | P3J13F FF, P3J13C FF, E3J1330 FF | 100% |  |  |  |  | 53,688.5 | 53,688.5 | P3J13D | P3J13D | 860 | J13 | 00 | 2JD8840 | 200 | 200 | 400 | P | LND | 0 | P | J | PJ33 | LUZ2 | INS | LND |  |
| HPJJ13 | Diff.PressureT. (J13) PO/Fabr./Transport to Site | level of effort | 317d | 2010-05-26 A | 2011-08-16 A | P3J13L SS | 100% |  |  |  |  |  |  | HPJJ13 | HPJJ13 | 86B |  | 00 |  | 200 | 200 | 400 | E | LND | L2 | P | J | PJ33 | LUZ2 | INS | LND | DFA |
| HPJJ13B | Pressure Trans.(J13B) PO/Fabr./Transport to Site | level of effort | 358d | 2010-05-26 A | 2011-10-13 | P3J13BL SS, P3J13CL SS |  | 30d | 68d | 0d |  |  |  | HPJJ13B | HPJJ13B | 86B |  | 00 |  | 200 | 200 | 400 | E | LND | L2 | P | J | PJ33 | LUZ2 | INS | LND | DFA |
| P3J13BL | J13B Pressure Transm. - Lead Time/Fabrication |  | 178d | 2010-05-26 A | 2010-11-19 A | P3J13BD | 100% |  |  |  | TB26 - 2 - Manuf and Delivy |  |  | P3J13BL | P3J13BL | 860 | J13B | 00 | 2JD8690 | 200 | 200 | 400 | P | LND | 0 | P | J | PJ36 | LUZ2 | INS | LND | DEL |
| P3J13L | J13 Diff.-/Press.Transm.(F/L) - Lead Time/Fabrication |  | 189d | 2010-05-26 A | 2010-11-30 A | P3J13D | 100% |  |  |  | TB26 - 2 - Manuf and Delivy |  |  | P3J13L | P3J13L | 860 | J13 | 00 | 2JD8840 | 200 | 200 | 400 | P | LND | 0 | P | J | PJ36 | LUZ2 | INS | LND | DEL |
| P3J04ED | J04E Var.Area Flow.(Rotam.) - PO issued | milestone | 0d | 2010-05-26 A | 2010-05-26 A | P3J04EF FF, P3J04EC FF, E3J04E30 FF, P3J04EE | 100% |  |  |  |  | 82,598 | 82,598 | P3J04ED | P3J04ED | 860 | J04E | 00 | 2JD7330 | 200 | 200 | 400 | P | LND | 0 | P | J | PJ33 | LUZ2 | INS | LND |  |
| P3J12AD | J12A Radar Level M. - PO issued | milestone | 0d | 2010-05-26 A | 2010-05-26 A | P3J12AC FF+240d, P3J12AF FF, E3J12A30 FF | 100% |  |  |  |  | 8,259.5 | 8,259.5 | P3J12AD | P3J12AD | 860 | J12A | 00 | 2JD8440 | 200 | 200 | 400 | P | LND | 0 | P | J | PJ33 | LUZ2 | INS | LND |  |
| HPJJ04E | Rotameters (J04E) PO/Fabr./Transport to Site | level of effort | 218d | 2010-05-27 A | 2011-03-31 A | P3J04EL SS | 100% |  |  |  |  |  |  | HPJJ04E | HPJJ04E | 86B |  | 00 |  | 200 | 200 | 400 | E | LND | L2 | P | J | PJ33 | LUZ2 | INS | LND | DFA |
| HPJJ12A | Radar Level M. (J12A) PO/Fabr./Transport to Site | level of effort | 316d | 2010-05-27 A | 2011-08-16 A | P3J12AL SS | 100% |  |  |  |  |  |  | HPJJ12A | HPJJ12A | 86B |  | 00 |  | 200 | 200 | 400 | E | LND | L2 | P | J | PJ33 | LUZ2 | INS | LND | DFA |
| P3J04EL | J04E Var.Area Flow.(Rotam.) - Lead Time/Fab. |  | 203d | 2010-05-27 A | 2010-12-15 A | P3J04ED | 100% |  |  |  | TB26 - 2 - Manuf and Delivy |  |  | P3J04EL | P3J04EL | 860 | J04E | 00 | 2JD7330 | 200 | 200 | 400 | P | LND | 0 | P | J | PJ36 | LUZ2 | INS | LND | DEL |
| P3J07BA | J07B Switches&Alarms - Prepare/Issue RFQ |  | 6d | 2010-05-27 A | 2010-06-03 A | E3J07B10 | 100% |  |  |  |  |  |  | P3J07BA | P3J07BA | 860 | J07B | 00 | 2JD9490 | 200 | 200 | 400 | P | LEI | 0 | P | J | PJ31 | LUZ2 | INS | LND | DEV |
| P3J12AL | J12A Radar Level M. - Lead Time/Fab. |  | 188d | 2010-05-27 A | 2010-11-30 A | P3J12AD | 100% |  |  |  | TB26 - 2 - Manuf and Delivy |  |  | P3J12AL | P3J12AL | 860 | J12A | 00 | 2JD8440 | 200 | 200 | 400 | P | LND | 0 | P | J | PJ36 | LUZ2 | INS | LND | DEL |
| P3J13AF | J13A Pressure Gauges - Bid tab Client appr. |  | 6d | 2010-05-28 A | 2010-06-04 A | E3J13A30 | 100% |  |  |  |  |  |  | P3J13AF | P3J13AF | 860 | J13A | 00 | 2JD8480 | 200 | 200 | 400 | P | PMT | 0 | P | J | PJ32 | LUZ2 | INS | PMT |  |
| P3J13CF | J13C Pressure Switches - Bid tab Client appr. |  | 5d | 2010-05-28 A | 2010-06-03 A | E3J13C30 | 100% |  |  |  |  |  |  | P3J13CF | P3J13CF | 860 | J13C | 00 | 2JD8960 | 200 | 200 | 400 | P | PMT | 0 | P | J | PJ32 | LUZ2 | INS | LND |  |
| P3J06AA | J06A Power Supp Cabinets - Prepare/Issue RFQ |  | 4d | 2010-05-31 A | 2010-06-03 A | E3J06A10 | 100% |  |  |  |  |  |  | P3J06AA | P3J06AA | 860 | J06A | 00 | 2JD9640 | 200 | 200 | 400 | P | LND | 0 | P | J | PJ21 | LUZ2 | INS | LND | DEV |
| P3J06BA | J06B Interface/Special Dev. Cabinets (E+I) - Prepare/Issue RFQ |  | 4d | 2010-05-31 A | 2010-06-03 A | E3J06B10 | 100% |  |  |  |  |  |  | P3J06BA | P3J06BA | 860 | J06B | 00 | 2JD9640 | 200 | 200 | 400 | P | LND | 0 | P | J | PJ21 | LUZ2 | INS | LND | DEV |

Notes:
- P3J04AD2: Expenses: 900A 37801.2
- HPJJ04A: UDF_Actictity Name (Russia): Расходомер Кориолиса (J04A), заказ на поставку/изготовление/транспортировка на площадку
- P3J02DD2: Expenses: 900A 125790
- HPJJ02D: UDF_Actictity Name (Russia): Пробковые клапаны (J02D), заказ на поставку/изготовление/транспортировка на площадку
- HPJJ12B: UDF_Actictity Name (Russia): Магнитные уровнемеры (J12B), заказ на поставку/изготовление/транспортировка на площадку
- P3J02AD: Expenses: 900A 121655
- HPJJ02A: UDF_Actictity Name (Russia): Клапаны PCV (J02A), заказ на поставку/изготовление/транспортировка на площадку
- P3J12BD: Expenses: 900A 16520
- P3J01AD2: Expenses: 900A 630000
- HPJJ01A: UDF_Actictity Name (Russia): Шаровые клапаны (J01A), заказ на поставку/изготовление/транспортировка на площадку
- P3J02CD2: Expenses: 900A 44695.2
- HPJJ02C: UDF_Actictity Name (Russia): Двустворчатые клапаны (J02C), заказ на поставку/изготовление/транспортировка на площадку
- P3J04CD: Expenses: 900A 33039
- HPJJ04C: UDF_Actictity Name (Russia): Ограничительные диафрагмы/трубки Вентури (J04C), заказ на поставку/изготовление/транспортировка на площадку
- P3J02BD2: Expenses: 900A 33060.2
- HPJJ02B: UDF_Actictity Name (Russia): Ножевые задвижки (J02B), заказ на поставку/изготовление/транспортировка на площадку
- P3J06D2: Expenses: 900A 1680000
- P3J07AB: Expenses: 900A 4130.1
- P3J18D: Expenses: 900A 8417
- HPJJ18: UDF_Actictity Name (Russia): Система взвешивания (J18), заказ на поставку/изготовление/транспортировка на площадку
- P3J14BD: Expenses: 900A 4129.5
- HPJJ14B: UDF_Actictity Name (Russia): Термометры (J14B), заказ на поставку/изготовление/транспортировка на площадку
- P3J14D: Expenses: 900A 82597.8
- HPJJ14: UDF_Actictity Name (Russia): Датчики температуры (J14), заказ на поставку/изготовление/транспортировка на площадку
- P3J13BD: Expenses: 900A 82597.8
- P3J13D: Expenses: 900A 53688.5
- HPJJ13: UDF_Actictity Name (Russia): Датчики перепада давления (J13), заказ на поставку/изготовление/транспортировка на площадку
- HPJJ13B: UDF_Actictity Name (Russia): Датчики давления (J13B), заказ на поставку/изготовление/транспортировка на площадку
- P3J04ED: Expenses: 900A 82598
- P3J12AD: Expenses: 900A 8259.5
- HPJJ04E: UDF_Actictity Name (Russia): Ротаметры (J04E), заказ на поставку/изготовление/транспортировка на площадку
- HPJJ12A: UDF_Actictity Name (Russia): Уровнемер-радар (J12A), заказ на поставку/изготовление/транспортировка на площадку

| ID | Activity | Type | Duration | Start | Finish | Predecessors | Complete | Remaining | Total float | Free float | Calendar | Cost | Actual cost | UDF_SAVE ACTID | UDF_SAVE ACT ID | Department | Type of Work | Constr. Area | Inquiry/Order No | PMT-Area | PMT-Schedule Org | PMT-Discipline | PMT-Phase | PMT-Doc. Type | PMT-Respons. | Zeigen/n. Zeigen | WBS Phase | WBS Discipline | WBS Type of Work | WBS Objects | IMS | UPT |
| --- | --- | --- | --- | --- | --- | --- | --- | --- | --- | --- | --- | --- | --- | --- | --- | --- | --- | --- | --- | --- | --- | --- | --- | --- | --- | --- | --- | --- | --- | --- | --- | --- |
| P3J17A | J17 Instrument Cable - Prepare/Issue RFQ |  | 5d | 2010-05-31 A | 2010-06-04 A | E3J1710 | 100% |  |  |  |  |  |  | P3J17A | P3J17A | 860 | J17 | 00 | 2JD9530 | 200 | 200 | 400 | P | DEV | LEI | 0 | P | J | PJ31 | LUZ2 | INS | LND |
| P3J06AB | J06A Power Supply Cabinets - RFQ issued | milestone | 0d | 2010-06-03 A | 2010-06-03 A | P3J06AA FF | 100% |  |  |  |  | 7,149 | 7,149 | P3J06AB | P3J06AB | 860 | J06A | 00 | 2JD9640 | 200 | 200 | 400 | P | DEV | LND | 0 | P | J | PJ21 | LUZ2 | INS | LND |
| P3J06BB | J06B Interface/Special Dev. Cabinets (E+I) - RFQ issued | milestone | 0d | 2010-06-03 A | 2010-06-03 A | P3J06BA FF | 100% |  |  |  |  | 14,351 | 14,351 | P3J06BB | P3J06BB | 860 | J06B | 00 | 2JD9640 | 200 | 200 | 400 | P | DEV | LND | 0 | P | J | PJ21 | LUZ2 | INS | LND |
| P3J07BB | J07B Switches&Alarms - RFQ issued | milestone | 0d | 2010-06-03 A | 2010-06-03 A | P3J07BA FF | 100% |  |  |  |  |  |  | P3J07BB | P3J07BB | 860 | J07B | 00 | 2JD9490 | 200 | 200 | 400 | P | DEV | LEI | 0 | P | J | PJ31 | LUZ2 | INS | LND |
| P3J17B | J17 Instrument Cable - RFQ issued | milestone | 0d | 2010-06-04 A | 2010-06-04 A | P3J17A FF | 100% |  |  |  |  |  |  | P3J17B | P3J17B | 860 | J17 | 00 | 2JD9530 | 200 | 200 | 400 | P | DEV | LEI | 0 | P | J | PJ31 | LUZ2 | INS | LND |
| P3J13CD | J13C Pressure Switches - PO issued | milestone | 0d | 2010-06-10 A | 2010-06-10 A | E3J13C30 FF, P3J13CC FF, P3J13CF FF | 100% |  |  |  |  | 16,519.25 | 16,519.25 | P3J13CD | P3J13CD | 860 | J13C | 00 | 2JD8960 | 200 | 200 | 400 | P |  | LND | 0 | P | J | PJ33 | LUZ2 | INS | LND |
| P3J13CL | J13C Pressure Switches - Lead Time/Fabrication |  | 232d | 2010-06-11 A | 2011-01-31 A | P3J13CD | 100% |  |  |  | TB26 - 2 - Manuf and Delivy |  |  | P3J13CL | P3J13CL | 860 | J13C | 00 | 2JD8960 | 200 | 200 | 400 | P | DEL | LND | 0 | P | J | PJ36 | LUZ2 | INS | LND |
| P3J13AD | J13A Pressure Gauges - PO issued | milestone | 0d | 2010-06-18 A | 2010-06-18 A | E3J13A30 FF, P3J13AF FF, P3J13AC FF | 100% |  |  |  |  | 16,519.5 | 16,519.5 | P3J13AD | P3J13AD | 860 | J13A | 00 | 2JD8480 | 200 | 200 | 400 | P |  | LND | 0 | P | J | PJ33 | LUZ2 | INS | LND |
| P3J13AL | J13A Pressure Gauges - Lead Time/Fabrication |  | 219d | 2010-06-19 A | 2011-01-26 A | P3J13AD | 100% |  |  |  | TB26 - 2 - Manuf and Delivy |  |  | P3J13AL | P3J13AL | 860 | J13A | 00 | 2JD8480 | 200 | 200 | 400 | P | DEL | LND | 0 | P | J | PJ36 | LUZ2 | INS | LND |
| HPJJ13A | Pressure Gauges(J13A) PO/Fabr./Transport to Site | level of effort | 299d | 2010-06-21 A | 2011-08-16 A | P3J13AL SS | 100% |  |  |  |  |  |  | HPJJ13A | HPJJ13A | 86B |  | 00 |  | 200 | 200 | 400 | E | DFA | LND | L2 | P | J | PJ33 | LUZ2 | INS | LND |
| P3J07CC | J07C Local Indicat. Panels -Eval./Negotiation |  | 48d | 2010-06-22 A | 2010-08-26 A | E3J07C20 FF, P3J07CB | 100% |  |  |  |  |  |  | P3J07CC | P3J07CC | 860 | J07C | 00 | 2JD9500 | 200 | 200 | 400 | P |  | LEI | 0 | P | J | PJ32 | LUZ2 | INS | LND |
| P3J06BC | J06B Interface/Special Dev. Cabinets (E+I) -Eval./Negotiation |  | 84d | 2010-06-29 A | 2010-10-22 A | P3J06BB, E3J06B20 FF+10d | 100% |  |  |  |  |  |  | P3J06BC | P3J06BC | 860 | J06B | 00 | 2JD9640 | 200 | 200 | 400 | P |  | LND | 0 | P | J | PJ22 | LUZ2 | INS | LND |
| P3J04IF | J04I Ultrasonic Flowm. - Bid tab Client appr. |  | 7d | 2010-07-01 A | 2010-07-09 A | E3J04I30 | 100% |  |  |  |  |  |  | P3J04IF | P3J04IF | 860 | J04I | 00 | 2JD8500 | 200 | 200 | 400 | P |  | PMT | 0 | P | J | PJ32 | LUZ2 | INS | PMT |
| P3J06AC | J06A Power Supply Cabinet -Eval./Negotiation |  | 82d | 2010-07-01 A | 2010-10-22 A | P3J06AB, E3J06A20 FF+10d | 100% |  |  |  |  |  |  | P3J06AC | P3J06AC | 860 | J06A | 00 | 2JD9640 | 200 | 200 | 400 | P |  | LND | 0 | P | J | PJ22 | LUZ2 | INS | LND |
| P3J14AF | J14A Thermowell+Elements - Bid tab Client appr. |  | 7d | 2010-07-06 A | 2010-07-14 A | E3J14A30 | 100% |  |  |  |  |  |  | P3J14AF | P3J14AF | 860 | J14A | 00 | 2JD8720 | 200 | 200 | 400 | P |  | PMT | 0 | P | J | PJ32 | LUZ2 | INS | LND |
| P3J17C | J17 Instrument Cable - Eval./Negotiation |  | 199d | 2010-07-12 A | 2011-04-19 A | E3J1720 FF | 100% |  |  |  |  |  |  | P3J17C | P3J17C | 860 | J17 | 00 | 2JD9530 | 200 | 200 | 400 | P |  | LEI | 0 | P | J | PJ32 | LUZ2 | INS | LND |
| P3J07BC | J07B Switches&Alarms -Eval./Negotiation |  | 51d | 2010-07-14 A | 2010-09-22 A | E3J07B20 FF, P3J07BB | 100% |  |  |  |  |  |  | P3J07BC | P3J07BC | 860 | J07B | 00 | 2JD9490 | 200 | 200 | 400 | P |  | LEI | 0 | P | J | PJ32 | LUZ2 | INS | LND |
| P3J06X0 | J06 DCS / SIS - Review Graphics Typicals |  | 15d | 2010-07-27 A | 2010-08-16 A | P3J06L SS+115d | 100% |  |  |  |  |  |  | P3J06X0 | P3J06X0 | 860 | J06 | 00 | 2JD9220 | 200 | 200 | 400 | P |  | LND | 0 | P | J | PJ27 | LUZ2 | INS | LND |
| P3J04AX | J04A Coriolis Mass Flowmeter - Final Inspection | milestone | 0d | 2010-08-03 A | 2010-08-03 A | E3J04A50, P3J04AL FF-10d | 100% |  |  |  | TB26 - 2 - Manuf and Delivy | 68,042.25 | 68,042.25 | P3J04AX | P3J04AX | 860 | J04A | 00 | 2JD7280 | 200 | 200 | 400 | P |  | LND | 0 | P | J | PJ37 | LUZ2 | INS | LND |
| P3J04BX | J04B Vortex Flowmeter - Final Inspection | milestone | 0d | 2010-08-03 A | 2010-08-03 A | E3J04B50 FS-5d, P3J04BL FF-10d | 100% |  |  |  | TB26 - 2 - Manuf and Delivy | 104,073.3 | 104,073.3 | P3J04BX | P3J04BX | 860 | J04B | 00 | 2JD9260 | 200 | 200 | 400 | P |  | LND | 0 | P | J | PJ37 | LUZ2 | INS | LND |
| P3J06D3 | J06 DCS / SIS - PO issued (Main Order) | milestone | 0d | 2010-08-04 A | 2010-08-04 A | P3J06D2 FF+85d, E3J0637 | 100% |  |  |  |  |  |  | P3J06D3 | P3J06D3 | 860 | J06 | 00 | 2JD9220 | 200 | 200 | 400 | P |  | LND | 0 | P | J | PJ23 | LUZ2 | B | LND |
| P3J12DB2 | J12D Vibration Fork Level Switch - revised RFQ issued | milestone | 0d | 2010-08-05 A | 2010-08-05 A | P3J12DB | 100% |  |  |  |  |  |  | P3J12DB2 | P3J12DB2 | 860 | J12D | 00 | 2JD9190 | 200 | 200 | 400 | P | DEV | LEI | 0 | P | J | PJ31 | LUZ2 | INS | LND |
| P3J14AD | J14A Thermowell+Elements - PO issued | milestone | 0d | 2010-08-09 A | 2010-08-09 A | E3J14A30 FF, P3J14AC FF, P3J14AF FF | 100% |  |  |  |  | 74,338.25 | 74,338.25 | P3J14AD | P3J14AD | 860 | J14A | 00 | 2JD8720 | 200 | 200 | 400 | P |  | LND | 0 | P | J | PJ33 | LUZ2 | INS | LND |
| P3J14AL | J14A Thermowell+Elements - Lead Time/Fabrication |  | 183d | 2010-08-10 A | 2011-02-11 A | P3J14AD, F3110 FF | 100% |  |  |  | TB26 - 2 - Manuf and Delivy |  |  | P3J14AL | P3J14AL | 860 | J14A | 00 | 2JD8720 | 200 | 200 | 400 | P | DEL | LND | 0 | P | J | PJ36 | LUZ2 | INS | LND |
| P3J07CF | J07C Local Indicat. Panels - Bid tab Client appr. |  | 5d | 2010-08-12 A | 2010-08-18 A | E3J07C30 | 100% |  |  |  |  |  |  | P3J07CF | P3J07CF | 860 | J07C | 00 | 2JD9500 | 200 | 200 | 400 | P |  | PMT | 0 | P | J | PJ32 | LUZ2 | INS | PMT |
| HPJJ05 | MPS/CMS (J05) PO/Fabr./Transport to Site | level of effort | 239d | 2010-08-19 A | 2011-07-22 A | P3J05L SS | 100% |  |  |  |  |  |  | HPJJ05 | HPJJ05 | 86B |  | 00 |  | 200 | 200 | 400 | E | DFA | LND | L2 | P | J | PJ33 | LUZ2 | INS | LND |
| P3J05L | J05 MPS/CMS - Lead Time/Fabrication |  | 168d | 2010-08-19 A | 2011-02-05 A | P3J05D | 100% |  |  |  | TB26 - 2 - Manuf and Delivy |  |  | P3J05L | P3J05L | 860 | J05 | 00 | 2JD7520 | 200 | 200 | 400 | P | DEL | LND | 0 | P | J | PJ26 | LUZ2 | INS | LND |
| P3J05D | J05 MPS/CMS - PO issued | milestone | 0d | 2010-08-19 A | 2010-08-19 A | P3J05C FF, P3J05F FF | 100% |  |  |  |  | 326,000 | 326,000 | P3J05D | P3J05D | 860 | J05 | 00 | 2JD7520 | 200 | 200 | 400 | P |  | LND | 0 | P | J | PJ23 | LUZ2 | INS | LND |
| P3J14G | J14 Gost R Certificate to russ. customs | milestone | 0d | 2010-08-25 A | 2010-08-25 A | P3J14N1 FF-90d | 100% |  |  |  | TB26 - 2 - Manuf and Delivy |  |  | P3J14G | P3J14G | 860 | J14 | 00 | 2JD8710 | 200 | 200 | 400 | P |  | LND | 0 | P | J | PJ38 | LUZ2 | INS | LND |
| P3J04ID | J04I Ultrasonic Flowm. - PO issued | milestone | 0d | 2010-08-26 A | 2010-08-26 A | E3J04I30 FF, P3J04IF FF, P3J04IC FF | 100% |  |  |  |  | 74,338 | 74,338 | P3J04ID | P3J04ID | 860 | J04I | 00 | 2JD8500 | 200 | 200 | 400 | P |  | LND | 0 | P | J | PJ33 | LUZ2 | INS | LND |
| P3J07CD | J07C Local Indicat. Panels - PO issued | milestone | 0d | 2010-08-26 A | 2010-08-26 A | P3J07CF, P3J07CC | 100% |  |  |  |  |  |  | P3J07CD | P3J07CD | 860 | J07C | 00 | 2JD9500 | 200 | 200 | 400 | P |  | LEI | 0 | P | J | PJ33 | LUZ2 | INS | LND |
| HPJJ04I | Ultrasonic's (J04I) PO/Fabr./Transport to Site | level of effort | 233d | 2010-08-27 A | 2011-07-22 A | P3J04IL SS | 100% |  |  |  |  |  |  | HPJJ04I | HPJJ04I | 86B |  | 00 |  | 200 | 200 | 400 | E | DFA | LND | L2 | P | J | PJ33 | LUZ2 | INS | LND |
| P3J02AG | J02A Gost R Certificate to russ. customs | milestone | 0d | 2010-08-27 A | 2010-08-27 A | P3J02AN FF-90d | 100% |  |  |  | TB26 - 2 - Manuf and Delivy |  |  | P3J02AG | P3J02AG | 860 | J02A | 00 | 2AJ2660 | 200 | 200 | 400 | P |  | LND | 0 | P | J | PJ38 | LUZ2 | INS | LND |
| P3J04CG | J04C Gost R Certificate to russ. customs | milestone | 0d | 2010-08-27 A | 2010-08-27 A | P3J04CN FF-90d | 100% |  |  |  | TB26 - 2 - Manuf and Delivy |  |  | P3J04CG | P3J04CG | 860 | J04C | 00 | 2JD7320 | 200 | 200 | 400 | P |  | LND | 0 | P | J | PJ38 | LUZ2 | INS | LND |
| P3J04IL | J04I Ultrasonic Flowm. - Lead Time/Fabrication |  | 159d | 2010-08-27 A | 2011-02-04 A | P3J04ID | 100% |  |  |  | TB26 - 2 - Manuf and Delivy |  |  | P3J04IL | P3J04IL | 860 | J04I | 00 | 2JD8500 | 200 | 200 | 400 | P | DEL | LND | 0 | P | J | PJ36 | LUZ2 | INS | LND |
| P3J07CL | J07C Local Indicat. Panels - Lead Time/Fabrication |  | 102d | 2010-08-27 A | 2010-12-06 A | P3J07CD | 100% |  |  |  | TB26 - 2 - Manuf and Delivy |  |  | P3J07CL | P3J07CL | 860 | J07C | 00 | 2JD9500 | 200 | 200 | 400 | P | DEL | LEI | 0 | P | J | PJ36 | LUZ2 | INS | LND |
| P3J02D2 | J02 Control Valves - PO issued (Equip.) | milestone | 0d | 2010-08-27 A | 2010-08-27 A | P3J02F FF, P3J02C FF, P3J02E, E3J0230 FF | 100% |  |  |  |  | 273,437.5 | 273,437.5 | P3J02D2 | P3J02D2 | 860 | J02 | 00 | 2AJ3030 | 200 | 200 | 400 | P |  | LND | 0 | P | J | PJ33 | LUZ2 | INS | LND |
| HPJJ02 | Control Valves (J02) PO/Fabr./Transport to Site | level of effort | 168d | 2010-08-30 A | 2011-04-25 A | P3J02L SS | 100% |  |  |  |  |  |  | HPJJ02 | HPJJ02 | 86B |  | 00 |  | 200 | 200 | 400 | E | DFA | LND | L2 | P | J | PJ33 | LUZ2 | INS | LND |
| P3J02L | J02 Control Valves - Lead Time/Fabrication |  | 211d | 2010-08-30 A | 2011-03-31 A | P3J02D1, P3J02D2 | 100% |  |  |  | TB26 - 2 - Manuf and Delivy |  |  | P3J02L | P3J02L | 860 | J02 | 00 | 2AJ3030 | 200 | 200 | 400 | P | DEL | LND | 0 | P | J | PJ36 | LUZ2 | INS | LND |
| P3J15F | J15 Winterization Enclosures - Bid tab Client appr. |  | 5d | 2010-08-30 A | 2010-09-03 A | E3J1530 | 100% |  |  |  |  |  |  | P3J15F | P3J15F | 860 | J15 | 00 | 2JD9450 | 200 | 200 | 400 | P |  | PMT | 0 | P | J | PJ32 | LUZ2 | INS | LND |
| P3J04AG | J04A Gost R Certificate to russ. customs | milestone | 0d | 2010-09-01 A | 2010-09-01 A | P3J04AN FF-90d | 100% |  |  |  | TB26 - 2 - Manuf and Delivy |  |  | P3J04AG | P3J04AG | 860 | J04A | 00 | 2JD7280 | 200 | 200 | 400 | P |  | LND | 0 | P | J | PJ38 | LUZ2 | INS | LND |
| P3J04BG | J04B Gost R Certificate to russ. customs | milestone | 0d | 2010-09-01 A | 2010-09-01 A | P3J04BN FF-90d | 100% |  |  |  | TB26 - 2 - Manuf and Delivy |  |  | P3J04BG | P3J04BG | 860 | J04B | 00 | 2JD9260 | 200 | 200 | 400 | P |  | LND | 0 | P | J | PJ38 | LUZ2 | INS | LND |
| P3J18G | J18 Gost R Certificate to russ. customs | milestone | 0d | 2010-09-01 A | 2010-09-01 A | P3J18N FF-90d | 100% |  |  |  | TB26 - 2 - Manuf and Delivy |  |  | P3J18G | P3J18G | 860 | J18 | 00 | J18 | 200 | 200 | 400 | P |  | LND | 0 | P | J | PJ38 | LUZ2 | INS | LND |
| P3J15D | J15 Winterization Enclosures - PO issued | milestone | 0d | 2010-09-08 A | 2010-09-08 A | P3J15F FF, P3J15C FF, E3J1530 FF | 100% |  |  |  |  |  |  | P3J15D | P3J15D | 860 | J15 | 00 | 2JD9450 | 200 | 200 | 400 | P |  | LEI | 0 | P | J | PJ33 | LUZ2 | INS | LND |
| P3J07BF | J07B Switches&Alarms - Bid tab Client appr. |  | 5d | 2010-09-09 A | 2010-09-15 A | E3J07B30 | 100% |  |  |  |  |  |  | P3J07BF | P3J07BF | 860 | J07B | 00 | 2JD9490 | 200 | 200 | 400 | P |  | PMT | 0 | P | J | PJ32 | LUZ2 | INS | PMT |
| P3J15L | J15 Winterization Enclosures - Fabrication / Integration Field Instr. |  | 313d | 2010-09-09 A | 2011-07-22 A | P3J15D | 100% |  |  |  | TB26 - 2 - Manuf and Delivy |  |  | P3J15L | P3J15L | 860 | J15 | 00 | 2JD9450 | 200 | 200 | 400 | P | DEL | LEI | 0 | P | J | PJ36 | LUZ2 | INS | LND |
| P3J06AF | J06A Power Cabinets - Bid tab Client appr. |  | 26d | 2010-09-14 A | 2010-10-19 A | E3J06A30 | 100% |  |  |  |  |  |  | P3J06AF | P3J06AF | 860 | J06A | 00 | 2JD9640 | 200 | 200 | 400 | P |  | LND | 0 | P | J | PJ22 | LUZ2 | INS | PMT |
| P3J18X | J18 Weighing for Vessels - Final Inspection | milestone | 0d | 2010-09-15 A | 2010-09-15 A | P3J18L FF-10d, E3J1850 | 100% |  |  |  | TB26 - 2 - Manuf and Delivy | 15,150.6 | 15,150.6 | P3J18X | P3J18X | 860 | J18 | 00 | J18 | 200 | 200 | 400 | P |  | LND | 0 | P | J | PJ37 | LUZ2 | INS | LND |
| P3J06BF | J06B Interface/Special Dev. Cabinets (E+I) - Bid tab Client appr. |  | 20d | 2010-09-22 A | 2010-10-19 A | E3J06B30 | 100% |  |  |  |  |  |  | P3J06BF | P3J06BF | 860 | J06B | 00 | 2JD9640 | 200 | 200 | 400 | P |  | PMT | 0 | P | J | PJ22 | LUZ2 | INS | PMT |
| P3J06FF | J06F PLC Network - Bid tab Client appr. |  | 20d | 2010-09-22 A | 2010-10-19 A | E3J06F30 | 100% |  |  |  |  |  |  | P3J06FF | P3J06FF | 860 | J06F | 00 | 2JD8450 | 200 | 200 | 400 | P |  | PMT | 0 | P | J | PJ32 | LUZ2 | INS | PMT |
| P3J07BD | J07B Switches&Alarms - PO issued | milestone | 0d | 2010-09-22 A | 2010-09-22 A | P3J07BF, P3J07BC | 100% |  |  |  |  |  |  | P3J07BD | P3J07BD | 860 | J07B | 00 | 2JD9490 | 200 | 200 | 400 | P |  | LEI | 0 | P | J | PJ33 | LUZ2 | INS | LND |
| P3J07BL | J07B Switches&Alarms - Lead Time/Fabrication |  | 79d | 2010-09-23 A | 2010-12-10 A | P3J07BD | 100% |  |  |  | TB26 - 2 - Manuf and Delivy |  |  | P3J07BL | P3J07BL | 860 | J07B | 00 | 2JD9490 | 200 | 200 | 400 | P | DEL | LEI | 0 | P | J | PJ36 | LUZ2 | INS | LND |
| P3J02AX | J02A PCV Valves - Final Inspection | milestone | 0d | 2010-09-24 A | 2010-09-24 A | E3J02A50 FF, P3J02AD, P3J02AL FF-7d | 100% |  |  |  | TB26 - 2 - Manuf and Delivy | 218,979.9 | 218,979.9 | P3J02AX | P3J02AX | 860 | J02A | 00 | 2AJ2660 | 200 | 200 | 400 | P |  | LND | 0 | P | J | PJ37 | LUZ2 | INS | LND |
| P3J04CX | J04C Orifice/Venturi T. - Final Inspection | milestone | 0d | 2010-10-04 A | 2010-10-04 A | P3J04CL FF-12d, P3J04CD, E3J04C50 | 100% |  |  |  | TB26 - 2 - Manuf and Delivy | 59,469.75 | 59,469.75 | P3J04CX | P3J04CX | 860 | J04C | 00 | 2JD7320 | 200 | 200 | 400 | P |  | LND | 0 | P | J | PJ37 | LUZ2 | INS | LND |
| P3J06FD | J06F PLC Network - PO issued | milestone | 0d | 2010-10-21 A | 2010-10-21 A | HPJ30 FF, P3J06FF FF, P3J06FC FF, E3J06F30 FF | 100% |  |  |  |  | 36,000 | 36,000 | P3J06FD | P3J06FD | 860 | J06F | 00 | 2JD8450 | 200 | 200 | 400 | P |  | LND | 0 | P | J | PJ33 | LUZ2 | INS | LND |
| HPJJ06F | PLC Network (J06F) PO/Fabr./Transport to Site | level of effort | 251d | 2010-10-22 A | 2011-10-13 | P3J06FL SS |  | 30d | -11d | 0d |  |  |  | HPJJ06F | HPJJ06F | 86B |  | 00 |  | 200 | 200 | 400 | E | DFA | LND | L2 | P | J | PJ33 | LUZ2 | INS | LND |
| P3J02DX | J02D ON/OFF Plug Valves - Final Inspection | milestone | 0d | 2010-10-22 A | 2010-10-22 A | P3J02DL FF-9d, E3J02D50 | 100% |  |  |  | TB26 - 2 - Manuf and Delivy | 226,421.55 | 226,421.55 | P3J02DX | P3J02DX | 860 | J02D | 00 | 2AJ3020 | 200 | 200 | 400 | P |  | LND | 0 | P | J | PJ37 | LUZ2 | INS | LND |
| P3J06FL | J06F PLC Network - Lead Time/Fabrication |  | 144d | 2010-10-22 A | 2011-03-17 A | P3J06FD | 100% |  |  |  | TB26 - 2 - Manuf and Delivy |  |  | P3J06FL | P3J06FL | 860 | J06F | 00 | 2JD8450 | 200 | 200 | 400 | P | DEL | LND | 0 | P | J | PJ36 | LUZ2 | INS | LND |
| P3J06AD | J06A Power Supply Cab. - PO issued | milestone | 0d | 2010-10-22 A | 2010-10-22 A | P3J06AF FF, P3J06AC FF, E3J06A30 FF | 100% |  |  |  |  | 35,745 | 35,745 | P3J06AD | P3J06AD | 860 | J06A | 00 | 2JD9640 | 200 | 200 | 400 | P |  | LND | 0 | P | J | PJ23 | LUZ2 | INS | LND |
| P3J06BD | J06B Interface/Special Dev. Cabinets (E+I) - PO issued | milestone | 0d | 2010-10-22 A | 2010-10-22 A | P3J06BC FF, P3J06BF FF | 100% |  |  |  |  | 71,755 | 71,755 | P3J06BD | P3J06BD | 860 | J06B | 00 | 2JD9640 | 200 | 200 | 400 | P |  | LND | 0 | P | J | PJ23 | LUZ2 | INS | LND |
| P3J06AL | J06A Power Supply Cabinets - Lead Time/Fab. |  | 172d | 2010-10-23 A | 2011-04-15 A | P3J06AD | 100% |  |  |  | TB26 - 2 - Manuf and Delivy |  |  | P3J06AL | P3J06AL | 860 | J06A | 00 | 2JD9640 | 200 | 200 | 400 | P | DEL | LND | 0 | P | J | PJ26 | LUZ2 | INS | LND |
| P3J06BL | J06B Interface/Special Dev. Cabinets (E+I) - Lead Time/Fab. |  | 192d | 2010-10-23 A | 2011-05-06 A | P3J06BD | 100% |  |  |  | TB26 - 2 - Manuf and Delivy |  |  | P3J06BL | P3J06BL | 860 | J06B | 00 | 2JD9640 | 200 | 200 | 400 | P | DEL | LND | 0 | P | J | PJ26 | LUZ2 | INS | LND |
| P3J02AM | J02A PCV Valves - Goods deliv. FOB | milestone | 0d | 2010-10-23 A | 2010-10-23 A | P3J02AL FF+5d, P3J02AX FF | 100% |  |  |  | TB26 - 2 - Manuf and Delivy | 72,993.3 | 72,993.3 | P3J02AM | P3J02AM | 860 | J02A | 00 | 2AJ2660 | 200 | 200 | 400 | P |  | LND | 0 | P | J | PJ38 | LUZ2 | INS | LND |
| P3J07CX | J07C Local Indicat. Panels - Final Inspection | milestone | 0d | 2010-10-25 A | 2010-10-25 A | P3J07CL FF-10d, E3J07C50, P3J07CD | 100% |  |  |  | TB26 - 2 - Manuf and Delivy |  |  | P3J07CX | P3J07CX | 860 | J07C | 00 | 2JD9500 | 200 | 200 | 400 | P |  | LEI | 0 | P | J | PJ37 | LUZ2 | INS | LND |
| HPJJ06A | UPS/Special Cabinets (J06A) PO/Fabr./Transport to Site | level of effort | 209d | 2010-10-25 A | 2011-08-16 A | P3J06AL SS | 100% |  |  |  |  |  |  | HPJJ06A | HPJJ06A | 86B |  | 00 |  | 200 | 200 | 400 | E | DFA | LND | L2 | P | J | PJ33 | LUZ2 | INS | LND |
| HPJJ06B | Interface Cab. (J06B) PO/Fabr./Transport to Site | level of effort | 209d | 2010-10-25 A | 2011-08-16 A | P3J06BL SS | 100% |  |  |  |  |  |  | HPJJ06B | HPJJ06B | 86B |  | 00 |  | 200 | 200 | 400 | E | DFA | LND | L2 | P | J | PJ33 | LUZ2 | INS | LND |
| P3J07AF | J07A Sample Boards - Bid tab Client appr. |  | 6d | 2010-10-26 A | 2010-11-02 A | E3J07A30 | 100% |  |  |  |  |  |  | P3J07AF | P3J07AF | 860 | J07A | 00 | 2JD9480 | 200 | 200 | 400 | P |  | PMT | 0 | P | J | PJ32 | LUZ2 | INS | PMT |
| P3J12DF | J12D Vibration Fork Level Switch - Bid tab Client appr. |  | 8d | 2010-10-27 A | 2010-11-05 A | E3J12D30 | 100% |  |  |  |  |  |  | P3J12DF | P3J12DF | 860 | J12D | 00 | 2JD9190 | 200 | 200 | 400 | P |  | PMT | 0 | P | J | PJ32 | LUZ2 | INS | PMT |
| P3J18M | J18 Weighing for Vessels - Goods deliv. FOB | milestone | 0d | 2010-10-29 A | 2010-10-29 A | P3J18X FF, P3J18L FF+10d | 100% |  |  |  | TB26 - 2 - Manuf and Delivy | 5,050.2 | 5,050.2 | P3J18M | P3J18M | 860 | J18 | 00 | J18 | 200 | 200 | 400 | P |  | LND | 0 | P | J | PJ38 | LUZ2 | INS | LND |
| P3J18N | J18 Weighing for Vessels - Transport to Site, depends an availability of TSF area's |  | 32d | 2010-10-30 A | 2010-11-30 A | P3J18M | 100% |  |  |  | TB26 - 2 - Manuf and Delivy |  |  | P3J18N | P3J18N | 860 | J18 | 00 | J18 | 200 | 200 | 400 | P |  | LND | 0 | P | J | PJ38 | LUZ2 | INS | LND |

Notes:
- P3J06AB: Expenses: 900A 7149
- P3J06BB: Expenses: 900A 14351
- P3J13CD: Expenses: 900A 16519.2
- P3J13AD: Expenses: 900A 16519.5
- HPJJ13A: UDF_Actictity Name (Russia): Манометры (J13A), заказ на поставку/изготовление/транспортировка на площадку
- P3J04AX: Expenses: 900A 68042.2
- P3J04BX: Expenses: 900A 104073
- P3J14AD: Expenses: 900A 74338.2
- HPJJ05: UDF_Actictity Name (Russia): MPS/CMS (J05), заказ на поставку/изготовление/транспортировка на площадку
- P3J05D: Expenses: 900A 326000
- P3J04ID: Expenses: 900A 74338
- HPJJ04I: UDF_Actictity Name (Russia): Ультразвуковые уровнемеры (J04I), заказ на поставку/изготовление/транспортировка на площадку
- P3J02D2: Expenses: 900A 273438
- HPJJ02: UDF_Actictity Name (Russia): Клапаны управления (J02), заказ на поставку/изготовление/транспортировка на площадку
- P3J18X: Expenses: 900A 15150.6
- P3J02AX: Expenses: 900A 218980
- P3J04CX: Expenses: 900A 59469.8
- P3J06FD: Expenses: 900A 36000
- HPJJ06F: UDF_Actictity Name (Russia): Сеть ПЛК (J06F), заказ на поставку/изготовление/транспортировка на площадку
- P3J02DX: Expenses: 900A 226422
- P3J06AD: Expenses: 900A 35745
- P3J06BD: Expenses: 900A 71755
- P3J02AM: Expenses: 900A 72993.3
- HPJJ06A: UDF_Actictity Name (Russia): Шкафы ИБП (J06A), заказ на поставку/изготовление/транспортировка на площадку
- HPJJ06B: UDF_Actictity Name (Russia): Интерфейсные шкафы (J06B), заказ на поставку/изготовление/транспортировка на площадку
- P3J18M: Expenses: 900A 5050.2

| ID | Activity | Type | Duration | Start | Finish | Predecessors | Complete | Calendar | Cost | Actual cost | UDF_SAVE ACTID | UDF_SAVE ACT ID | Department | Type of Work | Constr. Area | Inquiry/Order No | PMT-Area | PMT-Schedule Org | PMT-Discipline | PMT-Phase | PMT-Respons. | Zeigen/n. Zeigen | WBS Phase | WBS Discipline | WBS Type of Work | WBS Objects | IMS | UPT | PMT-Doc. Type |
| --- | --- | --- | --- | --- | --- | --- | --- | --- | --- | --- | --- | --- | --- | --- | --- | --- | --- | --- | --- | --- | --- | --- | --- | --- | --- | --- | --- | --- | --- |
| P3J07BG | J07B Gost R Certificate to russ. customs | milestone | 0d | 2010-11-01 A | 2010-11-01 A | P3J07BN FF-90d | 100% | TB26 - 2 - Manuf and Delivy |  |  | P3J07BG | P3J07BG | 860 | J07B | 00 | 2JD9490 | 200 | 200 | 400 | P | LEI | 0 | P | J | PJ38 | LUZ2 | INS | LND |  |
| P3J07AD | J07A Sample Boards - PO issued | milestone | 0d | 2010-11-03 A | 2010-11-03 A | HPJ30 FF, P3J07AC, P3J07AF | 100% |  | 20,650.5 | 20,650.5 | P3J07AD | P3J07AD | 860 | J07A | 00 | 2JD9480 | 200 | 200 | 400 | P | LND | 0 | P | J | PJ33 | LUZ2 | INS | LND |  |
| HPJJ07A | Sample Boards (J07A) PO/Fabr./Transport to Site | level of effort | 201d | 2010-11-04 A | 2011-08-16 A | P3J07AL SS | 100% |  |  |  | HPJJ07A | HPJJ07A | 86B |  | 00 |  | 200 | 200 | 400 | E | LND | L2 | P | J | PJ33 | LUZ2 | INS | LND | DFA |
| P3J07AL | J07A Sample Boards - Lead Time/Fabrication |  | 179d | 2010-11-04 A | 2011-05-05 A | P3J07AD | 100% | TB26 - 2 - Manuf and Delivy |  |  | P3J07AL | P3J07AL | 860 | J07A | 00 | 2JD9480 | 200 | 200 | 400 | P | LND | 0 | P | J | PJ36 | LUZ2 | INS | LND | DEL |
| P3J04CM | J04C Orifice/Venturi T. - Goods deliv. FOB | milestone | 0d | 2010-11-06 A | 2010-11-06 A | P3J04CL FF+22d, P3J04CX FF | 100% | TB26 - 2 - Manuf and Delivy | 19,823.25 | 19,823.25 | P3J04CM | P3J04CM | 860 | J04C | 00 | 2JD7320 | 200 | 200 | 400 | P | LND | 0 | P | J | PJ38 | LUZ2 | INS | LND |  |
| P3J14X | J14 Temp.Transm./Thermocouple - Final Inspection | milestone | 0d | 2010-11-15 A | 2010-11-15 A | E3J1450, P3J14L FF-10d | 100% | TB26 - 2 - Manuf and Delivy | 148,675.95 | 148,675.95 | P3J14X | P3J14X | 860 | J14 | 00 | 2JD8710 | 200 | 200 | 400 | P | LND | 0 | P | J | PJ37 | LUZ2 | INS | LND |  |
| P3J13BX | J13B Pressure Transm. - Final Inspection | milestone | 0d | 2010-11-16 A | 2010-11-16 A | E3J13B50, P3J13BL FF-10d | 100% | TB26 - 2 - Manuf and Delivy | 148,675.95 | 148,675.95 | P3J13BX | P3J13BX | 860 | J13B | 00 | 2JD8690 | 200 | 200 | 400 | P | LND | 0 | P | J | PJ37 | LUZ2 | INS | LND |  |
| P3J13X | J13 Diff.-/Press.Transm.(F/L) - Final Inspection (1st LOT) | milestone | 0d | 2010-11-16 A | 2010-11-16 A | E3J1350, P3J13L FF-10d | 100% | TB26 - 2 - Manuf and Delivy | 96,639.3 | 96,639.3 | P3J13X | P3J13X | 860 | J13 | 00 | 2JD8840 | 200 | 200 | 400 | P | LND | 0 | P | J | PJ37 | LUZ2 | INS | LND |  |
| P3J04EG | J04E Gost R Certificate to russ. customs | milestone | 0d | 2010-11-20 A | 2010-11-20 A | P3J04EN FF-90d | 100% | TB26 - 2 - Manuf and Delivy |  |  | P3J04EG | P3J04EG | 860 | J04E | 00 | 2JD7330 | 200 | 200 | 400 | P | LND | 0 | P | J | PJ38 | LUZ2 | INS | LND |  |
| P3J07CG | J07C Gost R Certificate to russ. customs | milestone | 0d | 2010-11-20 A | 2010-11-20 A | P3J07CN FF-90d | 100% | TB26 - 2 - Manuf and Delivy |  |  | P3J07CG | P3J07CG | 860 | J07C | 00 | 2JD9500 | 200 | 200 | 400 | P | LEI | 0 | P | J | PJ38 | LUZ2 | INS | LND |  |
| P3J12BG | J12B Gost R Certificate to russ. customs | milestone | 0d | 2010-11-20 A | 2010-11-20 A | P3J12BN FF-90d | 100% | TB26 - 2 - Manuf and Delivy |  |  | P3J12BG | P3J12BG | 860 | J12B | 00 | 2JD8470 | 200 | 200 | 400 | P | LND | 0 | P | J | PJ38 | LUZ2 | INS | LND |  |
| P3J02AN1 | J02A PCV Valves - Transport to Intertek (winterization enclosures) |  | 5d | 2010-11-22 A | 2010-11-26 A | P3J02AM | 100% | TB26 - 2 - Manuf and Delivy |  |  | P3J02AN1 | P3J02AN1 | 860 | J02A | 00 | 2AJ2660 | 200 | 200 | 400 | P | LND | 0 | P | J | PJ38 | LUZ2 | INS | LND |  |
| P3J04AM | J04A Coriolis Mass Flowmeter - Goods deliv. FOB | milestone | 0d | 2010-11-22 A | 2010-11-22 A | P3J04AL FF+10d, P3J04AD2, P3J04AX FF | 100% | TB26 - 2 - Manuf and Delivy | 22,680.75 | 22,680.75 | P3J04AM | P3J04AM | 860 | J04A | 00 | 2JD7280 | 200 | 200 | 400 | P | LND | 0 | P | J | PJ38 | LUZ2 | INS | LND |  |
| P3J04BM | J04B Vortex Flowmeter - Goods deliv. FOB | milestone | 0d | 2010-11-22 A | 2010-11-22 A | P3J04BX FF, P3J04BL FF+25d | 100% | TB26 - 2 - Manuf and Delivy | 34,691.1 | 34,691.1 | P3J04BM | P3J04BM | 860 | J04B | 00 | 2JD9260 | 200 | 200 | 400 | P | LND | 0 | P | J | PJ38 | LUZ2 | INS | LND |  |
| P3J12DD | J12D Vibration Fork Level Switch - PO issued | milestone | 0d | 2010-11-22 A | 2010-11-22 A | E3J12D30 FF, P3J12DB2 FF, P3J12DF FF, P3J12DC FF | 100% |  | 8,260 | 8,260 | P3J12DD | P3J12DD | 860 | J12D | 00 | 2JD9190 | 200 | 200 | 400 | P | LEI | 0 | P | J | PJ33 | LUZ2 | INS | LND |  |
| P3J04AN1 | J04A Coriolis Mass Flowmeter - Transport to Intertek (winterization enclosures) |  | 5d | 2010-11-23 A | 2010-11-27 A | P3J04AM | 100% | TB26 - 2 - Manuf and Delivy |  |  | P3J04AN1 | P3J04AN1 | 860 | J04A | 00 | 2JD7280 | 200 | 200 | 400 | P | LND | 0 | P | J | PJ38 | LUZ2 | INS | LND |  |
| P3J04BN1 | J04B Vortex Flowmeter - Transport to Intertek (winterization enclosures) |  | 5d | 2010-11-23 A | 2010-11-27 A | P3J04BM | 100% | TB26 - 2 - Manuf and Delivy |  |  | P3J04BN1 | P3J04BN1 | 860 | J04B | 00 | 2JD9260 | 200 | 200 | 400 | P | LND | 0 | P | J | PJ38 | LUZ2 | INS | LND |  |
| P3J12AX | J12A Radar Level M. - Final Inspection | milestone | 0d | 2010-11-23 A | 2010-11-23 A | E3J12A50, P3J12AL FF-8d | 100% | TB26 - 2 - Manuf and Delivy | 14,867.1 | 14,867.1 | P3J12AX | P3J12AX | 860 | J12A | 00 | 2JD8440 | 200 | 200 | 400 | P | LND | 0 | P | J | PJ37 | LUZ2 | INS | LND |  |
| P3J12DL | J12D Vibration Fork Level Switch -Lead Time/Fab. |  | 95d | 2010-11-23 A | 2011-02-28 A | P3J12DD | 100% | TB26 - 2 - Manuf and Delivy |  |  | P3J12DL | P3J12DL | 860 | J12D | 00 | 2JD9190 | 200 | 200 | 400 | P | LEI | 0 | P | J | PJ36 | LUZ2 | INS | LND | DEL |
| P3J13BM | J13B Pressure Transm. - Goods deliv. FOB | milestone | 0d | 2010-11-24 A | 2010-11-24 A | P3J13BL FF+5d, P3J13BX FF | 100% | TB26 - 2 - Manuf and Delivy | 49,558.65 | 49,558.65 | P3J13BM | P3J13BM | 860 | J13B | 00 | 2JD8690 | 200 | 200 | 400 | P | LND | 0 | P | J | PJ38 | LUZ2 | INS | LND |  |
| P3J14M | J14 Temp.Transm./Thermocouple - Goods deliv. FOB | milestone | 0d | 2010-11-24 A | 2010-11-24 A | P3J14X FF, P3J14L FF+4d | 100% | TB26 - 2 - Manuf and Delivy | 49,558.65 | 49,558.65 | P3J14M | P3J14M | 860 | J14 | 00 | 2JD8710 | 200 | 200 | 400 | P | LND | 0 | P | J | PJ38 | LUZ2 | INS | LND |  |
| P3J13BN1 | J13B Pressure Transm. - Transport to Intertek (winterization enclosures) |  | 5d | 2010-11-25 A | 2010-11-29 A | P3J13BM | 100% | TB26 - 2 - Manuf and Delivy |  |  | P3J13BN1 | P3J13BN1 | 860 | J13B | 00 | 2JD8690 | 200 | 200 | 400 | P | LND | 0 | P | J | PJ38 | LUZ2 | INS | LND |  |
| P3J14N1 | J14 Temp.Transm./Thermocouple- Transport to Intertek (winterization enclosures) |  | 5d | 2010-11-25 A | 2010-11-29 A | P3J14M | 100% | TB26 - 2 - Manuf and Delivy |  |  | P3J14N1 | P3J14N1 | 860 | J14 | 00 | 2JD8710 | 200 | 200 | 400 | P | LND | 0 | P | J | PJ38 | LUZ2 | INS | LND |  |
| P3J02AN2 | J02A PCV Valves - winterization enclosures (Intertek) |  | 63d | 2010-11-27 A | 2011-01-31 A | P3J15L SF+90d, P3J02AN1 | 100% | TB26 - 2 - Manuf and Delivy |  |  | P3J02AN2 | P3J02AN2 | 860 | J02A | 00 | 2AJ2660 | 200 | 200 | 400 | P | LND | 0 | P | J | PJ38 | LUZ2 | INS | LND |  |
| P3J02BG | J02B Gost R Certificate to russ. customs | milestone | 0d | 2010-11-28 A | 2010-11-28 A | P3J02BN FF-90d | 100% | TB26 - 2 - Manuf and Delivy |  |  | P3J02BG | P3J02BG | 860 | J02B | 00 | 2AJ3000 | 200 | 200 | 400 | P | LND | 0 | P | J | PJ38 | LUZ2 | INS | LND |  |
| P3J04AN2 | J04A Coriolis Mass Flowmeter - winterization enclosures (Intertek) |  | 62d | 2010-11-28 A | 2011-01-31 A | P3J04AN1, P3J15L SF+90d | 100% | TB26 - 2 - Manuf and Delivy |  |  | P3J04AN2 | P3J04AN2 | 860 | J04A | 00 | 2JD7280 | 200 | 200 | 400 | P | LND | 0 | P | J | PJ38 | LUZ2 | INS | LND |  |
| P3J04BN2 | J04B Vortex Flowmeter - winterization enclosures (Intertek) |  | 62d | 2010-11-28 A | 2011-01-31 A | P3J04BN1, P3J15L SF+90d | 100% | TB26 - 2 - Manuf and Delivy |  |  | P3J04BN2 | P3J04BN2 | 860 | J04B | 00 | 2JD9260 | 200 | 200 | 400 | P | LND | 0 | P | J | PJ38 | LUZ2 | INS | LND |  |
| P3J13BN2 | J13B Pressure Transm. - winterization enclosures (Intertek) |  | 60d | 2010-11-30 A | 2011-01-31 A | P3J13BN1 | 100% | TB26 - 2 - Manuf and Delivy |  |  | P3J13BN2 | P3J13BN2 | 860 | J13B | 00 | 2JD8690 | 200 | 200 | 400 | P | LND | 0 | P | J | PJ38 | LUZ2 | INS | LND |  |
| P3J14N2 | J14 Temp.Transm./Thermocouple- winterization enclosures (Intertek) |  | 60d | 2010-11-30 A | 2011-01-31 A | P3J15L SF+90d, P3J14N1 | 100% | TB26 - 2 - Manuf and Delivy |  |  | P3J14N2 | P3J14N2 | 860 | J14 | 00 | 2JD8710 | 200 | 200 | 400 | P | LND | 0 | P | J | PJ38 | LUZ2 | INS | LND |  |
| P3J02DM | J02D ON/OFF Plug Valves - Goods deliv. FOB | milestone | 0d | 2010-11-30 A | 2010-11-30 A | P3J02DX FF, P3J02DL FF | 100% | TB26 - 2 - Manuf and Delivy | 75,473.85 | 75,473.85 | P3J02DM | P3J02DM | 860 | J02D | 00 | 2AJ3020 | 200 | 200 | 400 | P | LND | 0 | P | J | PJ38 | LUZ2 | INS | LND |  |
| P3J04EX | J04E Var.Area Flow.(Rotam.) - Final Inspection (1st LOT) | milestone | 0d | 2010-11-30 A | 2010-11-30 A | E3J04E50 FF, P3J04EL FF-10d | 100% | TB26 - 2 - Manuf and Delivy | 148,675.95 | 148,675.95 | P3J04EX | P3J04EX | 860 | J04E | 00 | 2JD7330 | 200 | 200 | 400 | P | LND | 0 | P | J | PJ37 | LUZ2 | INS | LND |  |
| P3J12AM | J12A Radar Level M. - Goods deliv. FOB | milestone | 0d | 2010-11-30 A | 2010-11-30 A | P3J12AL FF, P3J12AX FF | 100% | TB26 - 2 - Manuf and Delivy | 4,955.7 | 4,955.7 | P3J12AM | P3J12AM | 860 | J12A | 00 | 2JD8440 | 200 | 200 | 400 | P | LND | 0 | P | J | PJ38 | LUZ2 | INS | LND |  |
| P3J13M | J13 Diff.-/Press.Transm.(F/L) - Goods deliv. FOB | milestone | 0d | 2010-11-30 A | 2010-11-30 A | P3J13L FF, P3J13X FF | 100% | TB26 - 2 - Manuf and Delivy | 32,213.1 | 32,213.1 | P3J13M | P3J13M | 860 | J13 | 00 | 2JD8840 | 200 | 200 | 400 | P | LND | 0 | P | J | PJ38 | LUZ2 | INS | LND |  |
| P3J07BX | J07B Switches&Alarms - Final Inspection | milestone | 0d | 2010-12-01 A | 2010-12-01 A | E3J07B50, P3J07BL FF-10d, P3J07BD | 100% | TB26 - 2 - Manuf and Delivy |  |  | P3J07BX | P3J07BX | 860 | J07B | 00 | 2JD9490 | 200 | 200 | 400 | P | LEI | 0 | P | J | PJ37 | LUZ2 | INS | LND |  |
| P3J12AN1 | J12A Radar Level M. - Transport to Intertek (winterization enclosures) |  | 5d | 2010-12-01 A | 2010-12-05 A | P3J12AM | 100% | TB26 - 2 - Manuf and Delivy |  |  | P3J12AN1 | P3J12AN1 | 860 | J12A | 00 | 2JD8440 | 200 | 200 | 400 | P | LND | 0 | P | J | PJ38 | LUZ2 | INS | LND |  |
| P3J13N1 | J13 Diff.-/Press.Transm.(F/L) - Transport to Intertek (winterization enclosures) |  | 5d | 2010-12-01 A | 2010-12-05 A | P3J13M | 100% | TB26 - 2 - Manuf and Delivy |  |  | P3J13N1 | P3J13N1 | 860 | J13 | 00 | 2JD8840 | 200 | 200 | 400 | P | LND | 0 | P | J | PJ38 | LUZ2 | INS | LND |  |
| P3J12AG | J12A Gost R Certificate to russ. customs | milestone | 0d | 2010-12-04 A | 2010-12-04 A | P3J12AN FF-90d | 100% | TB26 - 2 - Manuf and Delivy |  |  | P3J12AG | P3J12AG | 860 | J12A | 00 | 2JD8440 | 200 | 200 | 400 | P | LND | 0 | P | J | PJ38 | LUZ2 | INS | LND |  |
| P3J13G | J13 Gost R Certificate to russ. customs | milestone | 0d | 2010-12-04 A | 2010-12-04 A | P3J13N FF-90d | 100% | TB26 - 2 - Manuf and Delivy |  |  | P3J13G | P3J13G | 860 | J13 | 00 | 2JD8840 | 200 | 200 | 400 | P | LND | 0 | P | J | PJ38 | LUZ2 | INS | LND |  |
| P3J13BG | J13B Gost R Certificate to russ. customs | milestone | 0d | 2010-12-05 A | 2010-12-05 A | P3J13BN FF-90d | 100% | TB26 - 2 - Manuf and Delivy |  |  | P3J13BG | P3J13BG | 860 | J13B | 00 | 2JD8690 | 200 | 200 | 400 | P | LND | 0 | P | J | PJ38 | LUZ2 | INS | LND |  |
| P3J06X1 | J06 DCS / SIS - Software FAT (YEF-G) Main Part (remain. in Apr) |  | 54d | 2010-12-06 A | 2011-02-21 A | P3J06L SS+245d, E3J0642 | 100% |  |  |  | P3J06X1 | P3J06X1 | 860 | J06 | 00 | 2JD9220 | 200 | 200 | 400 | P | LND | 0 | P | J | PJ27 | LUZ2 | INS | LND |  |
| P3J12AN2 | J12A Radar Level M. - winterization enclosures (Intertek) |  | 54d | 2010-12-06 A | 2011-01-31 A | P3J12AN1, P3J15L SF+90d | 100% | TB26 - 2 - Manuf and Delivy |  |  | P3J12AN2 | P3J12AN2 | 860 | J12A | 00 | 2JD8440 | 200 | 200 | 400 | P | LND | 0 | P | J | PJ38 | LUZ2 | INS | LND |  |
| P3J13N2 | J13 Diff.-/Press.Transm.(F/L) - winterization enclosures (Intertek) |  | 72d | 2010-12-06 A | 2011-02-18 A | P3J15L SF+90d, P3J13N1 | 100% | TB26 - 2 - Manuf and Delivy |  |  | P3J13N2 | P3J13N2 | 860 | J13 | 00 | 2JD8840 | 200 | 200 | 400 | P | LND | 0 | P | J | PJ38 | LUZ2 | INS | LND |  |
| P3J14BG | J14B Gost R Certificate to russ. customs | milestone | 0d | 2010-12-06 A | 2010-12-06 A | P3J14BN FF-90d | 100% | TB26 - 2 - Manuf and Delivy |  |  | P3J14BG | P3J14BG | 860 | J14B | 00 | 2JD8700 | 200 | 200 | 400 | P | LND | 0 | P | J | PJ38 | LUZ2 | INS | LND |  |
| P3J07CM | J07C Local Indicat. Panels - Goods deliv. FOB | milestone | 0d | 2010-12-06 A | 2010-12-06 A | P3J07CL FF, P3J07CX FF | 100% | TB26 - 2 - Manuf and Delivy |  |  | P3J07CM | P3J07CM | 860 | J07C | 00 | 2JD9500 | 200 | 200 | 400 | P | LEI | 0 | P | J | PJ38 | LUZ2 | INS | LND |  |
| P3J12BX | J12B Magn.Lev.Gauges - Final Inspection | milestone | 0d | 2010-12-07 A | 2010-12-07 A | E3J12B50, P3J12BL FF-11d | 100% | TB26 - 2 - Manuf and Delivy | 29,736 | 29,736 | P3J12BX | P3J12BX | 860 | J12B | 00 | 2JD8470 | 200 | 200 | 400 | P | LND | 0 | P | J | PJ37 | LUZ2 | INS | LND |  |
| P3J14AG | J14A Gost R Certificate to russ. customs | milestone | 0d | 2010-12-14 A | 2010-12-14 A | P3J14AN FF-90d | 100% | TB26 - 2 - Manuf and Delivy |  |  | P3J14AG | P3J14AG | 860 | J14A | 00 | 2JD8720 | 200 | 200 | 400 | P | LND | 0 | P | J | PJ38 | LUZ2 | INS | LND |  |
| P3J01AG | J01A Gost R Certificate to russ. customs | milestone | 0d | 2010-12-15 A | 2010-12-15 A | P3J01AN FF-90d | 100% | TB26 - 2 - Manuf and Delivy |  |  | P3J01AG | P3J01AG | 860 | J01A | 00 | 2AJ2610 | 200 | 200 | 400 | P | LND | 0 | P | J | PJ38 | LUZ2 | INS | LND |  |
| P3J01G | J01 Gost R Certificate to russ. customs | milestone | 0d | 2010-12-15 A | 2010-12-15 A | P3J01N FF-90d | 100% | TB26 - 2 - Manuf and Delivy |  |  | P3J01G | P3J01G | 860 | J01 | 00 | 2AJ2620 | 200 | 200 | 400 | P | LND | 0 | P | J | PJ38 | LUZ2 | INS | LND |  |
| P3J02CG | J02C Gost R Certificate to russ. customs | milestone | 0d | 2010-12-15 A | 2010-12-15 A | P3J02CN FF-90d | 100% | TB26 - 2 - Manuf and Delivy |  |  | P3J02CG | P3J02CG | 860 | J02C | 00 | 2AJ3090 | 200 | 200 | 400 | P | LND | 0 | P | J | PJ38 | LUZ2 | INS | LND |  |
| P3J04IG | J04I Gost R Certificate to russ. customs | milestone | 0d | 2010-12-15 A | 2010-12-15 A | P3J04IN FF-90d | 100% | TB26 - 2 - Manuf and Delivy |  |  | P3J04IG | P3J04IG | 860 | J04I | 00 | 2JD8500 | 200 | 200 | 400 | P | LND | 0 | P | J | PJ38 | LUZ2 | INS | LND |  |
| P3J04EM | J04E Var.Area Flow.(Rotam.) - Goods deliv. FOB | milestone | 0d | 2010-12-15 A | 2010-12-15 A | P3J04EX FF, P3J04EL FF | 100% | TB26 - 2 - Manuf and Delivy | 49,558.65 | 49,558.65 | P3J04EM | P3J04EM | 860 | J04E | 00 | 2JD7330 | 200 | 200 | 400 | P | LND | 0 | P | J | PJ38 | LUZ2 | INS | LND |  |
| P3J07BM | J07B Switches&Alarms - Goods deliv. FOB | milestone | 0d | 2010-12-15 A | 2010-12-15 A | P3J07BL FF+5d, P3J07BX FF | 100% | TB26 - 2 - Manuf and Delivy |  |  | P3J07BM | P3J07BM | 860 | J07B | 00 | 2JD9490 | 200 | 200 | 400 | P | LEI | 0 | P | J | PJ38 | LUZ2 | INS | LND |  |
| P3J05G | J05 Gost R Certificate to russ. customs | milestone | 0d | 2010-12-22 A | 2010-12-22 A | P3J05N FF-90d | 100% | TB26 - 2 - Manuf and Delivy |  |  | P3J05G | P3J05G | 860 | J05 | 00 | 2JD7520 | 200 | 200 | 400 | P | LND | 0 | P | J | PJ28 | LUZ2 | INS | LND |  |
| P3J12BM | J12B Magn.Lev.Gauges - Goods deliv. FOB | milestone | 0d | 2010-12-29 A | 2010-12-29 A | P3J12BL FF+10d, P3J12BX FF | 100% | TB26 - 2 - Manuf and Delivy | 9,912 | 9,912 | P3J12BM | P3J12BM | 860 | J12B | 00 | 2JD8470 | 200 | 200 | 400 | P | LND | 0 | P | J | PJ38 | LUZ2 | INS | LND |  |
| P3J06X2 | J06 DCS / SIS - Hardware internal Test / Pre-FAT (YRU) |  | 30d | 2011-01-14 A | 2011-02-24 A | P3J06X1 SS+27d, E3J0646 | 100% |  |  |  | P3J06X2 | P3J06X2 | 860 | J06 | 00 | 2JD9220 | 200 | 200 | 400 | P | LND | 0 | P | J | PJ27 | LUZ2 | INS | LND |  |
| P3J05X | J05 MPS/CMS - Final Inspection | milestone | 0d | 2011-01-17 A | 2011-01-17 A | P3J05D, E3J0565, P3J05L FF-27d, E3J0550, E3J0560 | 100% | TB26 - 2 - Manuf and Delivy | 586,800 | 586,800 | P3J05X | P3J05X | 860 | J05 | 00 | 2JD7520 | 200 | 200 | 400 | P | LND | 0 | P | J | PJ27 | LUZ2 | INS | LND |  |
| P3J13AX | J13A Pressure Gauges - Final Inspection | milestone | 0d | 2011-01-18 A | 2011-01-18 A | P3J13AL FF-9d, E3J13A50 | 100% | TB26 - 2 - Manuf and Delivy | 29,735.1 | 29,735.1 | P3J13AX | P3J13AX | 860 | J13A | 00 | 2JD8480 | 200 | 200 | 400 | P | LND | 0 | P | J | PJ37 | LUZ2 | INS | LND |  |
| P3J13CX | J13C Pressure Switches - Final Inspection | milestone | 0d | 2011-01-18 A | 2011-01-18 A | P3J13CL FF-9d, E3J13C50 | 100% | TB26 - 2 - Manuf and Delivy | 29,734.65 | 29,734.65 | P3J13CX | P3J13CX | 860 | J13C | 00 | 2JD8960 | 200 | 200 | 400 | P | LND | 0 | P | J | PJ37 | LUZ2 | INS | LND |  |
| P3J14BX | J14B Temp. Gauges - Final Inspection | milestone | 0d | 2011-01-19 A | 2011-01-19 A | E3J14B50, P3J14BL FF-13d | 100% | TB26 - 2 - Manuf and Delivy | 7,433.1 | 7,433.1 | P3J14BX | P3J14BX | 860 | J14B | 00 | 2JD8700 | 200 | 200 | 400 | P | LND | 0 | P | J | PJ37 | LUZ2 | INS | LND |  |
| P3J06ED | J06E Junction Boxes - PO issued | milestone | 0d | 2011-01-20 A | 2011-01-20 A | E3J06E20, P3J06EB | 100% |  |  |  | P3J06ED | P3J06ED | 860 | J06E | 00 | 2JD9620 | 200 | 200 | 400 | P | LND | 0 | P | J | PJ23 | LUZ2 | INS | LND |  |
| P3J01AX | J01A Ball Valves - Final Inspection | milestone | 0d | 2011-01-21 A | 2011-01-21 A | E3J01A50 FF, P3J01AL FF-11d | 100% | TB26 - 2 - Manuf and Delivy | 1,134,000 | 1,134,000 | P3J01AX | P3J01AX | 860 | J01A | 00 | 2AJ2610 | 200 | 200 | 400 | P | LND | 0 | P | J | PJ37 | LUZ2 | INS | LND |  |
| P3J06EL | J06E Junction Boxes - Lead Time/Fab. |  | 105d | 2011-01-21 A | 2011-05-06 A | P3J06ED | 100% | TB26 - 2 - Manuf and Delivy |  |  | P3J06EL | P3J06EL | 860 | J06E | 00 | 2JD9620 | 200 | 200 | 400 | P | LND | 0 | P | J | PJ26 | LUZ2 | INS | LND | DEL |
| P3J01X | J01 Ball Valves PDS - Final Inspection | milestone | 0d | 2011-01-22 A | 2011-01-22 A | E3J0150, P3J01L FF-10d | 100% | TB26 - 2 - Manuf and Delivy | 74,276.1 | 74,276.1 | P3J01X | P3J01X | 860 | J01 | 00 | 2AJ2620 | 200 | 200 | 400 | P | LND | 0 | P | J | PJ37 | LUZ2 | INS | LND |  |
| P3J06AG | J06A Gost R Certificate to russ. customs | milestone | 0d | 2011-01-24 A | 2011-01-24 A | P3J06AN FF-90d | 100% | TB26 - 2 - Manuf and Delivy |  |  | P3J06AG | P3J06AG | 860 | J06A | 00 | 2JD9640 | 200 | 200 | 400 | P | LND | 0 | P | J | PJ28 | LUZ2 | INS | LND |  |
| P3J06BG | J06B Gost R Certificate to russ. customs | milestone | 0d | 2011-01-24 A | 2011-01-24 A | P3J06BN FF-90d | 100% | TB26 - 2 - Manuf and Delivy |  |  | P3J06BG | P3J06BG | 860 | J06B | 00 | 2JD9640 | 200 | 200 | 400 | P | LND | 0 | P | J | PJ28 | LUZ2 | INS | LND |  |
| P3J02BX | J02B Knife Valves - Final Inspection | milestone | 0d | 2011-01-25 A | 2011-01-25 A | E3J02B50, P3J02BL FF-7d | 100% | TB26 - 2 - Manuf and Delivy | 59,508.45 | 59,508.45 | P3J02BX | P3J02BX | 860 | J02B | 00 | 2AJ3000 | 200 | 200 | 400 | P | LND | 0 | P | J | PJ37 | LUZ2 | INS | LND |  |
| P3J06FG | J06F Gost R Certificate to russ. customs | milestone | 0d | 2011-01-25 A | 2011-01-25 A | P3J06FN FF-90d | 100% | TB26 - 2 - Manuf and Delivy |  |  | P3J06FG | P3J06FG | 860 | J06F | 00 | 2JD8450 | 200 | 200 | 400 | P | LND | 0 | P | J | PJ38 | LUZ2 | INS | LND |  |
| P3J07AG | J07A Gost R Certificate to russ. customs | milestone | 0d | 2011-01-25 A | 2011-01-25 A | P3J07AN FF-90d | 100% | TB26 - 2 - Manuf and Delivy |  |  | P3J07AG | P3J07AG | 860 | J07A | 00 | 2JD9480 | 200 | 200 | 400 | P | LND | 0 | P | J | PJ38 | LUZ2 | INS | LND |  |
| P3J14AX | J14A Thermowell+Elements - Final Inspection | milestone | 0d | 2011-01-26 A | 2011-01-26 A | E3J14A50, P3J14AL FF-10d | 100% | TB26 - 2 - Manuf and Delivy | 133,808.85 | 133,808.85 | P3J14AX | P3J14AX | 860 | J14A | 00 | 2JD8720 | 200 | 200 | 400 | P | LND | 0 | P | J | PJ37 | LUZ2 | INS | LND |  |
| P3J13AM | J13A Pressure Gauges - Goods deliv. FOB | milestone | 0d | 2011-01-26 A | 2011-01-26 A | P3J13AX FF, P3J13AL FF | 100% | TB26 - 2 - Manuf and Delivy | 9,911.7 | 9,911.7 | P3J13AM | P3J13AM | 860 | J13A | 00 | 2JD8480 | 200 | 200 | 400 | P | LND | 0 | P | J | PJ38 | LUZ2 | INS | LND |  |

Notes:
- P3J07AD: Expenses: 900A 20650.5
- HPJJ07A: UDF_Actictity Name (Russia): Панели образцов (J07A), заказ на поставку/изготовление/транспортировка на площадку
- P3J04CM: Expenses: 900A 19823.2
- P3J14X: Expenses: 900A 148676
- P3J13BX: Expenses: 900A 148676
- P3J13X: Expenses: 900A 96639.3
- P3J04AM: Expenses: 900A 22680.8
- P3J04BM: Expenses: 900A 34691.1
- P3J12DD: Expenses: 900A 8260
- P3J12AX: Expenses: 900A 14867.1
- P3J13BM: Expenses: 900A 49558.7
- P3J14M: Expenses: 900A 49558.7
- P3J02DM: Expenses: 900A 75473.9
- P3J04EX: Expenses: 900A 148676
- P3J12AM: Expenses: 900A 4955.7
- P3J13M: Expenses: 900A 32213.1
- P3J12BX: Expenses: 900A 29736
- P3J04EM: Expenses: 900A 49558.7
- P3J12BM: Expenses: 900A 9912
- P3J05X: Expenses: 900A 586800
- P3J13AX: Expenses: 900A 29735.1
- P3J13CX: Expenses: 900A 29734.7
- P3J14BX: Expenses: 900A 7433.1
- P3J01AX: Expenses: 900A 1134000
- P3J01X: Expenses: 900A 74276.1
- P3J02BX: Expenses: 900A 59508.4
- P3J14AX: Expenses: 900A 133809
- P3J13AM: Expenses: 900A 9911.7

| ID | Activity | Type | Duration | Start | Finish | Predecessors | Complete | Remaining | Planned start | Planned finish | Total float | Free float | Constraint | Calendar | Cost | Actual cost | UDF_SAVE ACTID | UDF_SAVE ACT ID | Department | Type of Work | Constr. Area | Inquiry/Order No | PMT-Area | PMT-Schedule Org | PMT-Discipline | PMT-Phase | PMT-Respons. | Zeigen/n. Zeigen | WBS Phase | WBS Discipline | WBS Type of Work | WBS Objects | IMS | UPT | PMT-Doc. Type |
| --- | --- | --- | --- | --- | --- | --- | --- | --- | --- | --- | --- | --- | --- | --- | --- | --- | --- | --- | --- | --- | --- | --- | --- | --- | --- | --- | --- | --- | --- | --- | --- | --- | --- | --- | --- |
| P3J13AN1 | J13A Pressure Gauges - Transport to Intertek (winterization enclosures) |  | 5d | 2011-01-27 A | 2011-01-31 A | P3J13AM | 100% |  |  |  |  |  |  | TB26 - 2 - Manuf and Delivy |  |  | P3J13AN1 | P3J13AN1 | 860 | J13A | 00 | 2JD8480 | 200 | 200 | 400 | P | LND | 0 | P | J | PJ38 | LUZ2 | INS | LND |  |
| P3J04IX | J04I Ultrasonic Flowm. - Final Inspection | milestone | 0d | 2011-01-30 A | 2011-01-30 A | P3J04IL FF-6d, E3J04I50 | 100% |  |  |  |  |  |  | TB26 - 2 - Manuf and Delivy | 133,808.85 | 133,808.85 | P3J04IX | P3J04IX | 860 | J04I | 00 | 2JD8500 | 200 | 200 | 400 | P | LND | 0 | P | J | PJ37 | LUZ2 | INS | LND |  |
| P3J13CM | J13C Pressure Switches - Goods deliv. FOB | milestone | 0d | 2011-01-31 A | 2011-01-31 A | P3J13CL FF, P3J13CX FF | 100% |  |  |  |  |  |  | TB26 - 2 - Manuf and Delivy | 9,911.55 | 9,911.55 | P3J13CM | P3J13CM | 860 | J13C | 00 | 2JD8960 | 200 | 200 | 400 | P | LND | 0 | P | J | PJ38 | LUZ2 | INS | LND |  |
| P3J02CX | J02C Butterfly Valves on/off - Final Inspection | milestone | 0d | 2011-01-31 A | 2011-01-31 A | P3J02CL FF-11d, E3J02C50 | 100% |  |  |  |  |  |  | TB26 - 2 - Manuf and Delivy | 80,451.45 | 80,451.45 | P3J02CX | P3J02CX | 860 | J02C | 00 | 2AJ3090 | 200 | 200 | 400 | P | LND | 0 | P | J | PJ37 | LUZ2 | INS | LND |  |
| P3J01AM | J01A Ball Valves - Goods deliv. FOB | milestone | 0d | 2011-01-31 A | 2011-01-31 A | P3J01AL FF, P3J01AX FF | 100% |  |  |  |  |  |  | TB26 - 2 - Manuf and Delivy | 378,000 | 378,000 | P3J01AM | P3J01AM | 860 | J01A | 00 | 2AJ2610 | 200 | 200 | 400 | P | LND | 0 | P | J | PJ38 | LUZ2 | INS | LND |  |
| P3J01M | J01 Ball Valves PDS - Goods deliv. FOB | milestone | 0d | 2011-01-31 A | 2011-01-31 A | P3J01X FF, P3J01L FF | 100% |  |  |  |  |  |  | TB26 - 2 - Manuf and Delivy | 24,758.7 | 24,758.7 | P3J01M | P3J01M | 860 | J01 | 00 | 2AJ2620 | 200 | 200 | 400 | P | LND | 0 | P | J | PJ38 | LUZ2 | INS | LND |  |
| P3J13AG | J13A Gost R Certificate to russ. customs | milestone | 0d | 2011-02-01 A | 2011-02-01 A | P3J13AN FF-90d | 100% |  |  |  |  |  |  | TB26 - 2 - Manuf and Delivy |  |  | P3J13AG | P3J13AG | 860 | J13A | 00 | 2JD8480 | 200 | 200 | 400 | P | LND | 0 | P | J | PJ38 | LUZ2 | INS | LND |  |
| P3J13AN2 | J13A Pressure Gauges - winterization enclosures (Intertek) |  | 50d | 2011-02-01 A | 2011-03-22 A | P3J13AN1 | 100% |  |  |  |  |  |  | TB26 - 2 - Manuf and Delivy |  |  | P3J13AN2 | P3J13AN2 | 860 | J13A | 00 | 2JD8480 | 200 | 200 | 400 | P | LND | 0 | P | J | PJ38 | LUZ2 | INS | LND |  |
| P3J04IM | J04I Ultrasonic Flowm. - Goods deliv. FOB | milestone | 0d | 2011-02-09 A | 2011-02-09 A | P3J04IX FF, P3J04IL FF+5d | 100% |  |  |  |  |  |  | TB26 - 2 - Manuf and Delivy | 44,602.95 | 44,602.95 | P3J04IM | P3J04IM | 860 | J04I | 00 | 2JD8500 | 200 | 200 | 400 | P | LND | 0 | P | J | PJ38 | LUZ2 | INS | LND |  |
| P3J02G | J02 Gost R Certificate to russ. customs | milestone | 0d | 2011-02-10 A | 2011-02-10 A | P3J02N FF-90d | 100% |  |  |  |  |  |  | TB26 - 2 - Manuf and Delivy |  |  | P3J02G | P3J02G | 860 | J02 | 00 | 2AJ3030 | 200 | 200 | 400 | P | LND | 0 | P | J | PJ38 | LUZ2 | INS | LND |  |
| P3J13CN1 | J13C Pressure Switches - Transport to Intertek (winterization enclosures) |  | 9d | 2011-02-10 A | 2011-02-18 A | P3J13CM | 100% |  |  |  |  |  |  | TB26 - 2 - Manuf and Delivy |  |  | P3J13CN1 | P3J13CN1 | 860 | J13C | 00 | 2JD8960 | 200 | 200 | 400 | P | LND | 0 | P | J | PJ38 | LUZ2 | INS | LND |  |
| P3J02BM | J02B Knife Valves - Goods deliv. FOB | milestone | 0d | 2011-02-10 A | 2011-02-10 A | P3J02BL FF+10d, P3J02BX FF | 100% |  |  |  |  |  |  | TB26 - 2 - Manuf and Delivy | 19,836.15 | 19,836.15 | P3J02BM | P3J02BM | 860 | J02B | 00 | 2AJ3000 | 200 | 200 | 400 | P | LND | 0 | P | J | PJ38 | LUZ2 | INS | LND |  |
| P3J14BM | J14B Temp. Gauges - Goods deliv. FOB | milestone | 0d | 2011-02-11 A | 2011-02-11 A | P3J14BX FF, P3J14BL FF | 100% |  |  |  |  |  |  | TB26 - 2 - Manuf and Delivy | 2,477.7 | 2,477.7 | P3J14BM | P3J14BM | 860 | J14B | 00 | 2JD8700 | 200 | 200 | 400 | P | LND | 0 | P | J | PJ38 | LUZ2 | INS | LND |  |
| P3J05M | J05 MPS/CMS - Goods deliv. FOB/FCA | milestone | 0d | 2011-02-12 A | 2011-02-12 A | P3J05X FF, P3J05L FF+7d | 100% |  |  |  |  |  |  | TB26 - 2 - Manuf and Delivy | 195,600 | 195,600 | P3J05M | P3J05M | 860 | J05 | 00 | 2JD7520 | 200 | 200 | 400 | P | LND | 0 | P | J | PJ28 | LUZ2 | INS | LND |  |
| P3J13CG | J13C Gost R Certificate to russ. customs | milestone | 0d | 2011-02-16 A | 2011-02-16 A | P3J13CN FF-90d | 100% |  |  |  |  |  |  | TB26 - 2 - Manuf and Delivy |  |  | P3J13CG | P3J13CG | 860 | J13C | 00 | 2JD8960 | 200 | 200 | 400 | P | LND | 0 | P | J | PJ38 | LUZ2 | INS | LND |  |
| P3J12DX | J12D Vibration Fork Level Switch - Final Inspection | milestone | 0d | 2011-02-17 A | 2011-02-17 A | P3J12DL FF-12d, E3J12D50 | 100% |  |  |  |  |  |  | TB26 - 2 - Manuf and Delivy | 14,868 | 14,868 | P3J12DX | P3J12DX | 860 | J12D | 00 | 2JD9190 | 200 | 200 | 400 | P | LEI | 0 | P | J | PJ37 | LUZ2 | INS | LND |  |
| P3J04IN2 | J04I Ultrasonic Flowm. - winterization enclosures (Intertek) |  | 65d | 2011-02-20 A | 2011-04-25 A | P3J04IM FS+10d, P3J15L SF+90d | 100% |  |  |  |  |  |  | TB26 - 2 - Manuf and Delivy |  |  | P3J04BN2 | P3J04IN2 | 860 | J04I | 00 | 2JD8500 | 200 | 200 | 400 | P | LND | 0 | P | J | PJ38 | LUZ2 | INS | LND |  |
| P3J13CN2 | J13C Pressure Switches - winterization enclosures (Intertek) |  | 54d | 2011-02-21 A | 2011-04-15 A | P3J13CN1 | 100% |  |  |  |  |  | start on 2011-02-21 | TB26 - 2 - Manuf and Delivy |  |  | P3J13CN2 | P3J13CN2 | 860 | J13C | 00 | 2JD8960 | 200 | 200 | 400 | P | LND | 0 | P | J | PJ38 | LUZ2 | INS | LND |  |
| P3J14AM | J14A Thermowell+Elements - Goods deliv. FOB | milestone | 0d | 2011-02-21 A | 2011-02-21 A | P3J14AL FF+10d, P3J14AX FF | 100% |  |  |  |  |  |  | TB26 - 2 - Manuf and Delivy | 44,602.95 | 44,602.95 | P3J14AM | P3J14AM | 860 | J14A | 00 | 2JD8720 | 200 | 200 | 400 | P | LND | 0 | P | J | PJ38 | LUZ2 | INS | LND |  |
| P3JU7G | J07 Gost R Certificate to russ. customs | milestone | 0d | 2011-02-28 A | 2011-02-28 A | P3J07N FF-90d | 100% |  |  |  |  |  |  | TB26 - 2 - Manuf and Delivy |  |  | P3JU7G | P3JU7G | 860 | J07 | 00 | 2JD7560 | 200 | 200 | 400 | P | LND | 0 | P | J | PJ38 | LUZ2 | INS | LND |  |
| P3J02CM | J02C Butterfly Valves on/off - Goods deliv. FOB | milestone | 0d | 2011-02-28 A | 2011-02-28 A | P3J02CL FF+3d, P3J02CX FF | 100% |  |  |  |  |  |  | TB26 - 2 - Manuf and Delivy | 26,817.15 | 26,817.15 | P3J02CM | P3J02CM | 860 | J02C | 00 | 2AJ3090 | 200 | 200 | 400 | P | LND | 0 | P | J | PJ38 | LUZ2 | INS | LND |  |
| P3J06X3 | J06 DCS / SIS - Hardware and integrated FAT (YEF-G, YRU) |  | 15d | 2011-03-01 A | 2011-03-21 A | P3J06X2 FS+2d | 100% |  |  |  |  |  |  |  |  |  | P3J06X3 | P3J06X3 | 860 | J06 | 00 | 2JD9220 | 200 | 200 | 400 | P | LND | 0 | P | J | PJ27 | LUZ2 | INS | LND |  |
| P3J06FX | J06F PLC Network - Final Inspection | milestone | 0d | 2011-03-04 A | 2011-03-04 A | E3J06F50, P3J06FL FF-14d | 100% |  |  |  |  |  |  | TB26 - 2 - Manuf and Delivy | 64,800 | 64,800 | P3J06FX | P3J06FX | 860 | J06F | 00 | 2JD8450 | 200 | 200 | 400 | P | LND | 0 | P | J | PJ37 | LUZ2 | INS | LND |  |
| P3J12DM | J12D Vibration Fork Level Switch - Goods deliv. FOB | milestone | 0d | 2011-03-05 A | 2011-03-05 A | P3J12DX FF, P3J12DL FF+5d | 100% |  |  |  |  |  |  | TB26 - 2 - Manuf and Delivy | 4,956 | 4,956 | P3J12DM | P3J12DM | 860 | J12D | 00 | 2JD9190 | 200 | 200 | 400 | P | LEI | 0 | P | J | PJ38 | LUZ2 | INS | LND |  |
| P3J12DG | J12D Gost R Certificate to russ. customs | milestone | 0d | 2011-03-06 A | 2011-03-06 A | P3J12DN FF-90d | 100% |  |  |  |  |  |  | TB26 - 2 - Manuf and Delivy |  |  | P3J12DG | P3J12DG | 860 | J12D | 00 | 2JD9190 | 200 | 200 | 400 | P | LEI | 0 | P | J | PJ38 | LUZ2 | INS | LND |  |
| P3J12DN1 | J12D Vibration Fork Level Switch - Transport to Intertek (winterization enclosures) |  | 5d | 2011-03-06 A | 2011-03-10 A | P3J12DM | 100% |  |  |  |  |  |  | TB26 - 2 - Manuf and Delivy |  |  | P3J12DN1 | P3J12DN1 | 860 | J12D | 00 | 2JD9190 | 200 | 200 | 400 | P | LND | 0 | P | J | PJ38 | LUZ2 | INS | LND |  |
| P3J04EN | J04E Var.Area Flow.(Rotam.) - Transport to Site (collection div. packages) |  | 25d | 2011-03-07 A | 2011-03-31 A | P3J04EM | 100% |  |  |  |  |  | start on or after 2011-03-07 | TB26 - 2 - Manuf and Delivy |  |  | P3J04EN | P3J04EN | 860 | J04E | 00 | 2JD7330 | 200 | 200 | 400 | P | LND | 0 | P | J | PJ38 | LUZ2 | INS | LND |  |
| P3J07BN | J07B Switches&Alarms - Transport to Site (collection div. packages) |  | 25d | 2011-03-07 A | 2011-03-31 A | P3J07BM | 100% |  |  |  |  |  | start on or after 2011-03-07 | TB26 - 2 - Manuf and Delivy |  |  | P3J07BN | P3J07BN | 860 | J07B | 00 | 2JD9490 | 200 | 200 | 400 | P | LEI | 0 | P | J | PJ38 | LUZ2 | INS | LND |  |
| P3J12BN | J12B Magn.Lev.Gauges - Transport to Site (collection div. packages) |  | 25d | 2011-03-07 A | 2011-03-31 A | P3J12BM | 100% |  |  |  |  |  | start on 2011-03-07 | TB26 - 2 - Manuf and Delivy |  |  | P3J12BN | P3J12BN | 860 | J12B | 00 | 2JD8470 | 200 | 200 | 400 | P | LND | 0 | P | J | PJ38 | LUZ2 | INS | LND |  |
| P3J12DN2 | J12D Vibration Fork Level Switch - winterization enclosures (Intertek) |  | 51d | 2011-03-11 A | 2011-04-30 A | P3J15L SF+90d, P3J12DN1 | 100% |  |  |  |  |  |  | TB26 - 2 - Manuf and Delivy |  |  | P3J12DN2 | P3J12DN2 | 860 | J12D | 00 | 2JD9190 | 200 | 200 | 400 | P | LND | 0 | P | J | PJ38 | LUZ2 | INS | LND |  |
| P3J06AX | J06A Power Supply Cabinets- Final Inspection | milestone | 0d | 2011-03-15 A | 2011-03-15 A | E3J06A50, P3J06AL FF-32d | 100% |  |  |  |  |  |  | TB26 - 2 - Manuf and Delivy | 64,341 | 64,341 | P3J06AX | P3J06AX | 860 | J06A | 00 | 2JD9640 | 200 | 200 | 400 | P | LND | 0 | P | J | PJ27 | LUZ2 | INS | LND |  |
| P3J06BX | J06B Interface/Special Dev. Cabinets (E+I) - Final Inspection | milestone | 0d | 2011-03-15 A | 2011-03-15 A | P3J06BL FF-32d, E3J06B50, P3J06BD | 100% |  |  |  |  |  |  | TB26 - 2 - Manuf and Delivy | 129,159 | 129,159 | P3J06BX | P3J06BX | 860 | J06B | 00 | 2JD9640 | 200 | 200 | 400 | P | LND | 0 | P | J | PJ27 | LUZ2 | INS | LND |  |
| P3J03G | J03 Gost R Certificate to russ. customs | milestone | 0d | 2011-03-17 A | 2011-03-17 A | P3J03N FF-90d | 100% |  |  |  |  |  |  | TB26 - 2 - Manuf and Delivy |  |  | P3J03G | P3J03G | 860 | J03 | 00 | 2JD7540 | 200 | 200 | 400 | P | LND | 0 | P | J | PJ38 | LUZ2 | INS | LND |  |
| P3J06X | J06 DCS / SIS - Final Inspection | milestone | 0d | 2011-03-21 A | 2011-03-21 A | E3J0665 FF, P3J06X3, EF40006 | 100% |  |  |  |  |  |  | TB26 - 2 - Manuf and Delivy | 3,024,000 | 3,024,000 | P3J06X | P3J06X | 860 | J06 | 00 | 2JD9220 | 200 | 200 | 400 | P | LND | 0 | P | J | PJ27 | LUZ2 | INS | LND |  |
| P3J02X | J02 Control Valves - Final Inspection | milestone | 0d | 2011-03-22 A | 2011-03-22 A | P3J02L FF-10d, E3J0250 | 100% |  |  |  |  |  |  | TB26 - 2 - Manuf and Delivy | 492,187.5 | 492,187.5 | P3J02X | P3J02X | 860 | J02 | 00 | 2AJ3030 | 200 | 200 | 400 | P | LND | 0 | P | J | PJ37 | LUZ2 | INS | LND |  |
| P3J06FM | J06F PLC Network - Goods deliv. FOB/FCA | milestone | 0d | 2011-03-27 A | 2011-03-27 A | P3J06FX FF, P3J06FL FF+10d | 100% |  |  |  |  |  |  | TB26 - 2 - Manuf and Delivy | 21,600 | 21,600 | P3J06FM | P3J06FM | 860 | J06F | 00 | 2JD8450 | 200 | 200 | 400 | P | LND | 0 | P | J | PJ38 | LUZ2 | INS | LND |  |
| P3J07X | J07 Analyser System - Final Inspection | milestone | 0d | 2011-03-28 A | 2011-03-28 A | E3J0750 FF, P3J07L FF-19d, E3J0760 | 100% |  |  |  |  |  |  | TB26 - 2 - Manuf and Delivy | 1,291,500 | 1,291,500 | P3J07X | P3J07X | 860 | J07 | 00 | 2JD7560 | 200 | 200 | 400 | P | LND | 0 | P | J | PJ37 | LUZ2 | INS | LND |  |
| P3J02M | J02 Control Valves - Goods deliv. FOB | milestone | 0d | 2011-04-05 A | 2011-04-05 A | P3J02L FF+5d, P3J02X FF | 100% |  |  |  |  |  |  | TB26 - 2 - Manuf and Delivy | 164,062.5 | 164,062.5 | P3J02M | P3J02M | 860 | J02 | 00 | 2AJ3030 | 200 | 200 | 400 | P | LND | 0 | P | J | PJ38 | LUZ2 | INS | LND |  |
| P3J02N | J02 Control Valves - Transport to Site |  | 20d | 2011-04-06 A | 2011-04-25 A | P3J02M | 100% |  |  |  |  |  |  | TB26 - 2 - Manuf and Delivy |  |  | P3J02N | P3J02N | 860 | J02 | 00 | 2AJ3030 | 200 | 200 | 400 | P | LND | 0 | P | J | PJ38 | LUZ2 | INS | LND |  |
| P3J01AN | J01A Ball Valves - Transport to Site |  | 22d | 2011-04-14 A | 2011-05-06 A | P3J01AM FS+45d | 100% |  |  |  |  |  | start on 2011-04-14 | TB26 - 2 - Manuf and Delivy |  |  | P3J01AN | P3J01AN | 860 | J01A | 00 | 2AJ2610 | 200 | 200 | 400 | P | LND | 0 | P | J | PJ38 | LUZ2 | INS | LND |  |
| P3J02CN | J02C Butterfly Valves on/off - Transport to Site |  | 22d | 2011-04-14 A | 2011-05-06 A | P3J02CM FS+44d | 100% |  |  |  |  |  |  | TB26 - 2 - Manuf and Delivy |  |  | P3J02CN | P3J02CN | 860 | J02C | 00 | 2AJ3090 | 200 | 200 | 400 | P | LND | 0 | P | J | PJ38 | LUZ2 | INS | LND |  |
| P3J01N | J01 Ball Valves PDS - Transport to Site |  | 21d | 2011-04-15 A | 2011-05-06 A | P3J01M FS+73d | 100% |  |  |  |  |  |  | TB26 - 2 - Manuf and Delivy |  |  | P3J01N | P3J01N | 860 | J01 | 00 | 2AJ2620 | 200 | 200 | 400 | P | LND | 0 | P | J | PJ38 | LUZ2 | INS | LND |  |
| P3J03X | J03 Nuclear Level Measurement - Final Inspection | milestone | 0d | 2011-04-19 A | 2011-04-19 A | P3J03L FF-7d, P3J03D2 FS+200d | 100% |  |  |  |  |  |  | TB26 - 2 - Manuf and Delivy | 252,749.25 | 252,749.25 | P3J03X | P3J03X | 860 | J03 | 00 | 2JD7540 | 200 | 200 | 400 | P | LND | 0 | P | J | PJ37 | LUZ2 | INS | LND |  |
| HPJJ17 | Instr. Cables (J17) PO/Fabr./Transport to Site | level of effort | 115d | 2011-04-19 A | 2011-09-27 | P3J17D |  | 19d | 2011-04-20 | 2011-09-27 | 31d | 0d |  |  |  |  | HPJJ17 | HPJJ17 | 86B |  | 00 |  | 200 | 200 | 400 | E | LND | L2 | P | J | PJ33 | LUZ2 | INS | LND | DFA |
| P3J17D | J17 Instrument Cable - PO issued | milestone | 0d | 2011-04-19 A | 2011-04-19 A | E3J1730, E3J1735 FF, E3J1720, P3J17C | 100% |  |  |  |  |  |  |  |  |  | P3J17D | P3J17D | 860 | J17 | 00 | 2JD9530 | 200 | 200 | 400 | P | LEI | 0 | P | J | PJ33 | LUZ2 | INS | LND |  |
| P3J07AX | J07A Sample Boards - Final Inspection | milestone | 0d | 2011-04-20 A | 2011-04-20 A | P3J07AL FF-15d, E3J07A50, P3J07AD | 100% |  |  |  |  |  |  | TB26 - 2 - Manuf and Delivy | 37,170.9 | 37,170.9 | P3J07AX | P3J07AX | 860 | J07A | 00 | 2JD9480 | 200 | 200 | 400 | P | LND | 0 | P | J | PJ37 | LUZ2 | INS | LND |  |
| P3J17L | J17 Instrument Cable - Lead Time/Fabrication |  | 107d | 2011-04-20 A | 2011-08-05 A | P3J17D | 100% |  |  |  |  |  |  | TB26 - 2 - Manuf and Delivy |  |  | P3J17L | P3J17L | 860 | J17 | 00 | 2JD9530 | 200 | 200 | 400 | P | LEI | 0 | P | J | PJ36 | LUZ2 | INS | LND | DEL |
| P3J03M | J03 Nuclear Level Measurement - Goods deliv. FOB/FCA | milestone | 0d | 2011-04-25 A | 2011-04-25 A | P3J03X FF, P3J03L FF | 100% |  |  |  |  |  |  | TB26 - 2 - Manuf and Delivy | 84,249.75 | 84,249.75 | P3J03M | P3J03M | 860 | J03 | 00 | 2JD7540 | 200 | 200 | 400 | P | LND | 0 | P | J | PJ38 | LUZ2 | INS | LND |  |
| P3J06AM | J06A Power Supply Cabinets- Goods deliv. FOB | milestone | 0d | 2011-05-06 A | 2011-05-06 A | P3J06AX FF, P3J06AL FF+20d | 100% |  |  |  |  |  |  | TB26 - 2 - Manuf and Delivy | 21,447 | 21,447 | P3J06AM | P3J06AM | 860 | J06A | 00 | 2JD9640 | 200 | 200 | 400 | P | LND | 0 | P | J | PJ28 | LUZ2 | INS | LND |  |
| P3J06EM | J06E Junction Boxes - Goods deliv. FOB | milestone | 0d | 2011-05-16 A | 2011-05-16 A | P3J06EL FS+10d | 100% |  |  |  |  |  |  | TB26 - 2 - Manuf and Delivy |  |  | P3J06EM | P3J06EM | 860 | J06E | 00 | 2JD9620 | 200 | 200 | 400 | P | LND | 0 | P | J | PJ28 | LUZ2 | INS | LND |  |
| P3J06BM | J06B Interface/Special Dev. Cabinets (E+I) - Goods deliv. FOB | milestone | 0d | 2011-05-18 A | 2011-05-18 A | P3J06BL FF+12d, P3J06BX FF | 100% |  |  |  |  |  |  | TB26 - 2 - Manuf and Delivy | 43,053 | 43,053 | P3J06BM | P3J06BM | 860 | J06B | 00 | 2JD9640 | 200 | 200 | 400 | P | LND | 0 | P | J | PJ28 | LUZ2 | INS | LND |  |
| P3J02AN | J02A PCV Valves - Transport to Site (collection with other packages) |  | 23d | 2011-05-19 A | 2011-06-10 A | P3J02AN2, P3J02AM | 100% |  |  |  |  |  |  | TB26 - 2 - Manuf and Delivy |  |  | P3J02AN | P3J02AN | 860 | J02A | 00 | 2AJ2660 | 200 | 200 | 400 | P | LND | 0 | P | J | PJ38 | LUZ2 | INS | LND |  |
| P3J04AN | J04A Coriolis Mass Flowmeter - Transport to Site (collection of div. packages) |  | 23d | 2011-05-19 A | 2011-06-10 A | P3J04AM, P3J04AN2 | 100% |  |  |  |  |  |  | TB26 - 2 - Manuf and Delivy |  |  | P3J04AN | P3J04AN | 860 | J04A | 00 | 2JD7280 | 200 | 200 | 400 | P | OWN | 0 | P | J | PJ38 | LUZ2 | INS | LND |  |
| P3J04BN | J04B Vortex Flowmeter - Transport to Site (collection of div. packages) |  | 23d | 2011-05-19 A | 2011-06-10 A | P3J04BM, P3J04BN2 | 100% |  |  |  |  |  |  | TB26 - 2 - Manuf and Delivy |  |  | P3J04BN | P3J04BN | 860 | J04B | 00 | 2JD9260 | 200 | 200 | 400 | P | LND | 0 | P | J | PJ38 | LUZ2 | INS | LND |  |
| P3J04CN | J04C Orifice/Venturi T. - Transport to Site (collection of div. packages) |  | 23d | 2011-05-19 A | 2011-06-10 A | P3J04CM | 100% |  |  |  |  |  |  | TB26 - 2 - Manuf and Delivy |  |  | P3J04CN | P3J04CN | 860 | J04C | 00 | 2JD7320 | 200 | 200 | 400 | P | LND | 0 | P | J | PJ38 | LUZ2 | INS | LND |  |
| P3J07AM | J07A Sample Boards - Goods deliv. FOB | milestone | 0d | 2011-05-20 A | 2011-05-20 A | P3J07AX FF, P3J07AL FF+15d | 100% |  |  |  |  |  |  | TB26 - 2 - Manuf and Delivy | 12,390.3 | 12,390.3 | P3J07AM | P3J07AM | 860 | J07A | 00 | 2JD9480 | 200 | 200 | 400 | P | LND | 0 | P | J | PJ38 | LUZ2 | INS | LND |  |
| P3J07M | J07 Analyser System - Goods deliv. FOB/FCA | milestone | 0d | 2011-05-26 A | 2011-05-26 A | P3J07L FF+10d, P3J07X FF | 100% |  |  |  |  |  |  | TB26 - 2 - Manuf and Delivy | 430,500 | 430,500 | P3J07M | P3J07M | 860 | J07 | 00 | 2JD7560 | 200 | 200 | 400 | P | LND | 0 | P | J | PJ38 | LUZ2 | INS | LND |  |
| P3J02DN | J02D ON/OFF Plug Valves - Transport to Site (collection of div. packages) |  | 21d | 2011-06-10 A | 2011-06-30 A | P3J02DM | 100% |  |  |  |  |  |  | TB26 - 2 - Manuf and Delivy |  |  | P3J02DN | P3J02DN | 860 | J02D | 00 | 2AJ3020 | 200 | 200 | 400 | P | LND | 0 | P | J | PJ38 | LUZ2 | INS | LND |  |
| P3J07CN | J07C Local Indicat. Panels - Transport to Site (collection div. packages) |  | 25d | 2011-06-20 A | 2011-07-14 A | P3J07CM | 100% |  |  |  |  |  |  | TB26 - 2 - Manuf and Delivy |  |  | P3J07CN | P3J07CN | 860 | J07C | 00 | 2JD9500 | 200 | 200 | 400 | P | LEI | 0 | P | J | PJ38 | LUZ2 | INS | LND |  |
| P3J14N | J14 Temp.Transm./Thermocouple- Transport to Site (collection of div. packages) |  | 25d | 2011-06-20 A | 2011-07-14 A | P3J14N2 | 100% |  |  |  |  |  |  | TB26 - 2 - Manuf and Delivy |  |  | P3J14N | P3J14N | 860 | J14 | 00 | 2JD8710 | 200 | 200 | 400 | P | LND | 0 | P | J | PJ38 | LUZ2 | INS | LND |  |
| P3J06M | J06 DCS / SIS - Goods delivered FOB/FCA | milestone | 0d | 2011-06-20 A | 2011-06-20 A | P3J06L FF+28d, P3J06X FF | 100% |  |  |  |  |  |  | TB26 - 2 - Manuf and Delivy | 1,008,000 | 1,008,000 | P3J06M | P3J06M | 860 | J06 | 00 | 2JD9220 | 200 | 200 | 400 | P | LND | 0 | P | J | PJ28 | LUZ2 | INS | LND |  |
| P3J07N | J07 Analyser System - Transport to Site |  | 21d | 2011-06-24 A | 2011-07-14 A | P3J07M, P3J100 FF | 100% |  |  |  |  |  | start on 2011-06-24 | TB26 - 2 - Manuf and Delivy |  |  | P3J07N | P3J07N | 860 | J07 | 00 | 2JD7560 | 200 | 200 | 400 | P | LND | 0 | P | J | PJ38 | LUZ2 | INS | LND |  |
| P3J06N | J06 DCS / SIS - Transport to Site |  | 20d | 2011-06-26 A | 2011-07-15 A | P3J100 FF, P3J06M FS+5d | 100% |  |  |  |  |  |  | TB26 - 2 - Manuf and Delivy |  |  | P3J06N | P3J06N | 860 | J06 | 00 | 2JD9220 | 200 | 200 | 400 | P | LND | 0 | P | J | PJ28 | LUZ2 | INS | LND |  |
| P3J06EN | J06E Junction Boxes - Transport to Site |  | 25d | 2011-06-28 A | 2011-07-22 A | P3J06EM FS+5d | 100% |  |  |  |  |  |  | TB26 - 2 - Manuf and Delivy |  |  | P3J06EN | P3J06EN | 860 | J06E | 00 | 2JD9620 | 200 | 200 | 400 | P | LND | 0 | P | J | PJ28 | LUZ2 | INS | LND |  |
| P3J04IN | J04I Ultrasonic Flowm. - Transport to Site (collection div. packages) |  | 24d | 2011-06-30 A | 2011-07-23 A | P3J04IN2 FS+30d, P3J04IM FS+30d | 100% |  |  |  |  |  |  | TB26 - 2 - Manuf and Delivy |  |  | P3J04IN | P3J04IN | 860 | J04I | 00 | 2JD8500 | 200 | 200 | 400 | P | LND | 0 | P | J | PJ38 | LUZ2 | INS | LND |  |
| P3J05N | J05 MPS/CMS - Transport to Site (collection div. packages) |  | 24d | 2011-06-30 A | 2011-07-23 A | P3J05M | 100% |  |  |  |  |  |  | TB26 - 2 - Manuf and Delivy |  |  | P3J05N | P3J05N | 860 | J05 | 00 | 2JD7520 | 200 | 200 | 400 | P | LND | 0 | P | J | PJ28 | LUZ2 | INS | LND |  |
| P3J06AN | J06A Power Supp Cabinets - Transport to Site |  | 30d | 2011-07-18 A | 2011-08-16 A | P3J06AM | 100% |  |  |  |  |  | start on 2011-07-18 | TB26 - 2 - Manuf and Delivy |  |  | P3J06AN | P3J06AN | 860 | J06A | 00 | 2JD9640 | 200 | 200 | 400 | P | LND | 0 | P | J | PJ28 | LUZ2 | INS | LND |  |
| P3J06BN | J06B Interface/Special Dev. Cabinets (E+I) - Transport to Site |  | 30d | 2011-07-18 A | 2011-08-16 A | P3J06BM FS+5d | 100% |  |  |  |  |  | start on 2011-07-18 | TB26 - 2 - Manuf and Delivy |  |  | P3J06BN | P3J06BN | 860 | J06B | 00 | 2JD9640 | 200 | 200 | 400 | P | LND | 0 | P | J | PJ28 | LUZ2 | INS | LND |  |
| P3J07AN | J07A Sample Boards - Transport to Site |  | 21d | 2011-07-27 A | 2011-08-16 A | P3J07AM FS+10d | 100% |  |  |  |  |  | start on 2011-07-27 | TB26 - 2 - Manuf and Delivy |  |  | P3J07AN | P3J07AN | 860 | J07A | 00 | 2JD9480 | 200 | 200 | 400 | P | LND | 0 | P | J | PJ38 | LUZ2 | INS | LND |  |
| P3J12AN | J12A Radar Level M. - Transport to Site (transport by temp. degree above zero) |  | 21d | 2011-07-27 A | 2011-08-16 A | P3J12AM, P3J12AN2 | 100% |  |  |  |  |  | start on or after 2011-07-27 | TB26 - 2 - Manuf and Delivy |  |  | P3J12AN | P3J12AN | 860 | J12A | 00 | 2JD8440 | 200 | 200 | 400 | P | LND | 0 | P | J | PJ38 | LUZ2 | INS | LND |  |

Notes:
- P3J04IX: Expenses: 900A 133809
- P3J13CM: Expenses: 900A 9911.55
- P3J02CX: Expenses: 900A 80451.4
- P3J01AM: Expenses: 900A 378000
- P3J01M: Expenses: 900A 24758.7
- P3J04IM: Expenses: 900A 44602.9
- P3J02BM: Expenses: 900A 19836.2
- P3J14BM: Expenses: 900A 2477.7
- P3J05M: Expenses: 900A 195600
- P3J12DX: Expenses: 900A 14868
- P3J14AM: Expenses: 900A 44602.9
- P3J02CM: Expenses: 900A 26817.2
- P3J06FX: Expenses: 900A 64800
- P3J12DM: Expenses: 900A 4956
- P3J06AX: Expenses: 900A 64341
- P3J06BX: Expenses: 900A 129159
- P3J06X: Expenses: 900A 3024000
- P3J02X: Expenses: 900A 492188
- P3J06FM: Expenses: 900A 21600
- P3J07X: Expenses: 900A 1291500
- P3J02M: Expenses: 900A 164062
- P3J03X: Expenses: 900A 252749
- HPJJ17: UDF_Actictity Name (Russia): Кабели КИП (J17), заказ на поставку/изготовление/транспортировка на площадку
- P3J07AX: Expenses: 900A 37170.9
- P3J03M: Expenses: 900A 84249.8
- P3J06AM: Expenses: 900A 21447
- P3J06BM: Expenses: 900A 43053
- P3J07AM: Expenses: 900A 12390.3
- P3J07M: Expenses: 900A 430500
- P3J06M: Expenses: 900A 1008000

| ID | WBS | Activity | Type | Duration | Start | Finish | Predecessors | Complete | Remaining | Total float | Free float | Constraint | Calendar | Cost | Actual cost | UDF_SAVE ACTID | UDF_SAVE ACT ID | Department | Type of Work | Constr. Area | Inquiry/Order No | PMT-Area | PMT-Schedule Org | PMT-Discipline | PMT-Phase | PMT-Respons. | Zeigen/n. Zeigen | WBS Phase | WBS Discipline | WBS Type of Work | WBS Objects | IMS | UPT | PMT-Doc. Type |
| --- | --- | --- | --- | --- | --- | --- | --- | --- | --- | --- | --- | --- | --- | --- | --- | --- | --- | --- | --- | --- | --- | --- | --- | --- | --- | --- | --- | --- | --- | --- | --- | --- | --- | --- |
| P3J12DN |  | J12D Vibration Fork Level Switch - Transport to Site |  | 21d | 2011-07-27 A | 2011-08-16 A | P3J12DN2 FS+86d, P3J12DM | 100% |  |  |  |  | TB26 - 2 - Manuf and Delivy |  |  | P3J12DN | P3J12DN | 860 | J12D | 00 | 2JD9190 | 200 | 200 | 400 | P | LEI | 0 | P | J | PJ38 | LUZ2 | INS | LND |  |
| P3J13AN |  | J13A Pressure Gauges - Transport to Site (collection of div. packages) |  | 21d | 2011-07-27 A | 2011-08-16 A | P3J13AN2, P3J13AM | 100% |  |  |  |  | TB26 - 2 - Manuf and Delivy |  |  | P3J13AN | P3J13AN | 860 | J13A | 00 | 2JD8480 | 200 | 200 | 400 | P | LND | 0 | P | J | PJ38 | LUZ2 | INS | LND |  |
| P3J13BN |  | J13B Pressure Transm. - Transport to Site (collection of div. packages) |  | 21d | 2011-07-27 A | 2011-08-16 A | P3J13BN2, P3J13BM | 100% |  |  |  |  | TB26 - 2 - Manuf and Delivy |  |  | P3J13BN | P3J13BN | 860 | J13B | 00 | 2JD8690 | 200 | 200 | 400 | P | LND | 0 | P | J | PJ38 | LUZ2 | INS | LND |  |
| P3J13N |  | J13 Diff.-/Press.Transm.(F/L) - Transport to Site (collection of div. packages) |  | 21d | 2011-07-27 A | 2011-08-16 A | P3J13M, P3J13N2 | 100% |  |  |  |  | TB26 - 2 - Manuf and Delivy |  |  | P3J13N | P3J13N | 860 | J13 | 00 | 2JD8840 | 200 | 200 | 400 | P | LND | 0 | P | J | PJ38 | LUZ2 | INS | LND |  |
| P3J14AN |  | J14A Thermowell+Elements - Transport to Site (collection of div. packages) |  | 21d | 2011-07-27 A | 2011-08-16 A | P3J14AM | 100% |  |  |  | start on or after 2011-07-27 | TB26 - 2 - Manuf and Delivy |  |  | P3J14AN | P3J14AN | 860 | J14A | 00 | 2JD8720 | 200 | 200 | 400 | P | LND | 0 | P | J | PJ38 | LUZ2 | INS | LND |  |
| P3J14BN |  | J14B Temp. Gauges - Transport to Site (collection of div. packages) |  | 21d | 2011-07-27 A | 2011-08-16 A | P3J14BM | 100% |  |  |  |  | TB26 - 2 - Manuf and Delivy |  |  | P3J14BN | P3J14BN | 860 | J14B | 00 | 2JD8700 | 200 | 200 | 400 | P | LND | 0 | P | J | PJ38 | LUZ2 | INS | LND |  |
| P3J17x |  | J17 Instrument Cable - Final Inspection | milestone | 0d | 2011-07-29 A | 2011-07-29 A | P3J17L FF-8d | 100% |  |  |  |  | TB26 - 2 - Manuf and Delivy |  |  | P3J17x | P3J17x | 860 | J17 | 00 | 2JD9530 | 200 | 200 | 400 | P | LEI | 0 | P | J | PJ37 | LUZ2 | INS | LND |  |
| P3J17M |  | J17 Instrument Cable - Goods deliv. FOB | milestone | 0d | 2011-09-02 | 2011-09-02 | P3J17L FF+28d, P3J17x |  |  | 46d | 0d |  | TB26 - 2 - Manuf and Delivy |  |  | P3J17M | P3J17M | 860 | J17 | 00 | 2JD9530 | 200 | 200 | 400 | P | LEI | 0 | P | J | PJ38 | LUZ2 | INS | LND |  |
| P3J17N |  | J17 Instrument Cable - Transport to Site |  | 25d | 2011-09-03 | 2011-09-27 | P3J17M |  |  | 46d | 0d |  | TB26 - 2 - Manuf and Delivy |  |  | P3J17N | P3J17N | 860 | J17 | 00 | 2JD9530 | 200 | 200 | 400 | P | LEI | 0 | P | J | PJ38 | LUZ2 | INS | LND |  |
| P3J02BN |  | J02B Knife Valves - Transport to Site (transport by degree above zero) |  | 30d | 2011-09-19 | 2011-10-18 | P3J02BM |  |  | -96d | 0d | start on 2011-09-19 | TB26 - 2 - Manuf and Delivy |  |  | P3J02BN | P3J02BN | 860 | J02B | 00 | 2AJ3000 | 200 | 200 | 400 | P | LND | 0 | P | J | PJ38 | LUZ2 | INS | LND |  |
| P3J06FN |  | J06F PLC Network - Transport to Site (collection of div. packages) |  | 25d | 2011-09-19 | 2011-10-13 | P3J06FM FS+60d |  |  | -16d | 0d | start on 2011-09-19 | TB26 - 2 - Manuf and Delivy |  |  | P3J06FN | P3J06FN | 860 | J06F | 00 | 2JD8450 | 200 | 200 | 400 | P | LND | 0 | P | J | PJ38 | LUZ2 | INS | LND |  |
| P3J13CN |  | J13C Pressure Switches - Transport to Site |  | 25d | 2011-09-19 | 2011-10-13 | P3J13CM, P3J13CN2 FS+155d |  |  | 95d | 0d |  | TB26 - 2 - Manuf and Delivy |  |  | P3J13CN | P3J13CN | 860 | J13C | 00 | 2JD8960 | 200 | 200 | 400 | P | LND | 0 | P | J | PJ38 | LUZ2 | INS | LND |  |
| P3J03N |  | J03 Nuclear Level Meas. - Transport to Site |  | 20d | 2012-02-06 | 2012-02-25 | P3J100 FF, P3J03M FS+30d |  |  | -78d | 0d | start on or after 2012-02-06 | TB26 - 2 - Manuf and Delivy |  |  | P3J03N | P3J03N | 860 | J03 | 00 | 2JD7540 | 200 | 200 | 400 | P | LND | 0 | P | J | PJ38 | LUZ2 | INS | LND |  |
|  | S | **S Safety & Environment** |  |  | 2008-09-22 | 2011-10-21 |  |  |  |  |  |  |  |  |  |  |  |  |  |  |  |  |  |  |  |  |  |  |  |  |  |  |  |  |
| A1MECS01 |  | Inq. & Order Safety & Environmental Equipment |  | 152d | 2008-09-22 A | 2009-05-06 A | E3S0110 SS | 100% |  |  |  |  |  |  |  | A1MECS01 | A1MECS01 | 860 |  | 00 |  | 200 |  |  | P |  |  | P | S | 0000 | LUZ2 |  | LND |  |
| P3S06A |  | S06 Sprinkler System - Prepare/Issue RFQ |  | 5d | 2008-10-06 A | 2008-10-10 A | E3S0610 | 100% |  |  |  |  |  |  |  | P3S06A | P3S06A | 860 | S06 | 00 | 2SI1740 | 200 | 200 | 400 | P | LND | 0 | P | S | PS21 | LUZ2 | P | LND | DEV |
| P3S07A |  | S07 Deluge System - Prepare/Issue RFQ |  | 5d | 2008-10-06 A | 2008-10-10 A | E3S0710 | 100% |  |  |  |  |  |  |  | P3S07A | P3S07A | 860 | S07 | 00 | 2SI1730 | 200 | 200 | 400 | P | LND | 0 | P | S | PS21 | LUZ2 | P | LND | DEV |
| P3S01A |  | S01 Safety Relief Valves - Prepare/Issue RFQ |  | 4d | 2008-10-09 A | 2008-10-14 A | E3S0110, AD1330 FF | 100% |  |  |  |  |  |  |  | P3S01A | P3S01A | 860 | S01 | 00 | 2SI1760 | 200 | 200 | 400 | P | LND | 0 | P | S | PS21 | LUZ2 | PI | LND | DEV |
| P3S02A |  | S02 Rupture Disks - Prepare/Issue RFQ |  | 4d | 2008-10-09 A | 2008-10-14 A | E3S0210 | 100% |  |  |  |  |  |  |  | P3S02A | P3S02A | 860 | S02 | 00 | 2SI1750 | 200 | 200 | 400 | P | LND | 0 | P | S | PS21 | LUZ2 | P | LND | DEV |
| P3S06B |  | S06 Sprinkler System - RFQ issued | milestone | 0d | 2008-10-11 A | 2008-10-11 A | P3S06A FF | 100% |  |  |  |  |  | 25,750 | 25,750 | P3S06B | P3S06B | 860 | S06 | 00 | 2SI1740 | 200 | 200 | 400 | P | LND | 0 | P | S | PS21 | LUZ2 | P | LND | DEV |
| P3S07B |  | S07 Deluge System - RFQ issued | milestone | 0d | 2008-10-11 A | 2008-10-11 A | P3S07A FF | 100% |  |  |  |  |  | 25,750 | 25,750 | P3S07B | P3S07B | 860 | S07 | 00 | 2SI1730 | 200 | 200 | 400 | P | LND | 0 | P | S | PS21 | LUZ2 | P | LND | DEV |
| P3S01B |  | S01 Safety Relief Valves - RFQ issued | milestone | 0d | 2008-10-15 A | 2008-10-15 A | P3S01A FF | 100% |  |  |  |  |  | 32,550 | 32,550 | P3S01B | P3S01B | 860 | S01 | 00 | 2SI1760 | 200 | 200 | 400 | P | LND | 0 | P | S | PS21 | LUZ2 | PI | LND | DEV |
| P3S02B |  | S02 Rupture Disks - RFQ issued | milestone | 0d | 2008-10-15 A | 2008-10-15 A | P3S02A FF | 100% |  |  |  |  |  | 3,500 | 3,500 | P3S02B | P3S02B | 860 | S02 | 00 | 2SI1750 | 200 | 200 | 400 | P | LND | 0 | P | S | PS21 | LUZ2 | P | LND | DEV |
| P3S05A |  | S05 Gas Exting. Syst. - Prepare/Issue RFQ |  | 4d | 2008-10-30 A | 2008-11-05 A | E3S0510 | 100% |  |  |  |  |  |  |  | P3S05A | P3S05A | 860 | S05 | 00 | 2SI1770 | 200 | 200 | 400 | P | LND | 0 | P | S | PS21 | LUZ2 | P | LND | DEV |
| P3S05B |  | S05 Gas Exting. Syst. - RFQ issued | milestone | 0d | 2008-11-06 A | 2008-11-06 A | P3S05A FF | 100% |  |  |  |  |  | 24,500 | 24,500 | P3S05B | P3S05B | 860 | S05 | 00 | 2SI1770 | 200 | 200 | 400 | P | LND | 0 | P | S | PS21 | LUZ2 | P | LND | DEV |
| P3S08A |  | S08 Hydrants/Monitors - Prepare/Issue RFQ |  | 3d | 2008-12-12 A | 2008-12-16 A | E3S0810 | 100% |  |  |  |  |  |  |  | P3S08A | P3S08A | 860 | S08A | 00 | 2SI1810 | 200 | 200 | 400 | P | LND | 0 | P | S | PS21 | LUZ2 | P | LND | DEV |
| P3S08B |  | S08 Hydrants/Monitors - RFQ issued | milestone | 0d | 2008-12-17 A | 2008-12-17 A | P3S08A FF | 100% |  |  |  |  |  | 19,300 | 19,300 | P3S08B | P3S08B | 860 | S08A | 00 | 2SI1810 | 200 | 200 | 400 | P | LND | 0 | P | S | PS21 | LUZ2 | P | LND | DEV |
| A1MECS02 |  | Fabr.& Delivery Safety & Environmental Equipment |  | 200d | 2009-01-02 A | 2009-10-15 A | A1MECS01 SS+60d | 100% |  |  |  |  |  |  |  | A1MECS02 | A1MECS02 | 860 |  | 00 |  | 200 |  |  | P |  |  | P | S | 0000 | LUZ2 |  | LND |  |
| P3S01C |  | S01 Safety Relief Valves - Eval./Negotiation |  | 288d | 2009-01-26 A | 2010-03-17 A | P3S01B, E3S0120 FF | 100% |  |  |  |  |  |  |  | P3S01C | P3S01C | 860 | S01 | 00 | 2SI1760 | 200 | 200 | 400 | P | LND | 0 | P | S | PS22 | LUZ2 | P | LND |  |
| P3S02C |  | S02 Rupture Disks - Eval./Negotiation |  | 290d | 2009-02-23 A | 2010-04-20 A | P3S02B, E3S0220 FF | 100% |  |  |  |  |  |  |  | P3S02C | P3S02C | 860 | S02 | 00 | 2SI1750 | 200 | 200 | 400 | P | LND | 0 | P | S | PS22 | LUZ2 | P | LND |  |
| P3S02F |  | S02 Rupture Disks - Bid tab Client appr. |  | 47.12d | 2009-03-27 A | 2009-06-09 A | E3S0230 | 100% |  |  |  |  |  |  |  | P3S02F | P3S02F | 860 | S02 | 00 | 2SI1750 | 200 | 200 | 400 | P | PMT | 0 | P | S | PS22 | LUZ2 | P | LND |  |
| P3S01F |  | S01 Safety Relief Valves - Bid tab Client appr. |  | 35d | 2009-04-02 A | 2009-05-26 A | E3S0130 | 100% |  |  |  |  |  |  |  | P3S01F | P3S01F | 860 | S01 | 00 | 2SI1760 | 200 | 200 | 400 | P | PMT | 0 | P | S | PS22 | LUZ2 | P | LND |  |
| P3S08C |  | S08A Hydrants - Eval./Negotiation |  | 183d | 2009-09-23 A | 2010-06-17 A | E3S0820 FF, P3S08B | 100% |  |  |  |  |  |  |  | P3S08C | P3S08C | 860 | S08A | 00 | 2SI1810 | 200 | 200 | 400 | P | LND | 0 | P | S | PS22 | LUZ2 | P | LND |  |
| P3S10A |  | S10 Flame Arrestors - Prepare/Issue RFQ |  | 7d | 2009-09-28 A | 2009-10-06 A | E3S1010 | 100% |  |  |  |  |  |  |  | P3S10A | P3S10A | 860 | S10 | 00 | 2SI1880 | 200 | 200 | 400 | P | LND | 0 | P | S | PS21 | LUZ2 | P | LND | DEV |
| P3S10B |  | S10 Flame Arrestors - RFQ issued | milestone | 0d | 2009-10-06 A | 2009-10-06 A | P3S10A FF | 100% |  |  |  |  |  |  |  | P3S10B | P3S10B | 860 | S10 | 00 | 2SI1880 | 200 | 200 | 400 | P | LND | 0 | P | S | PS21 | LUZ2 | P | LND | DEV |
| P3S09A |  | S09 Minor FF Equipment - Prepare/Issue RFQ |  | 10d | 2009-10-19 A | 2009-10-30 A | E3S0910 | 100% |  |  |  |  |  |  |  | P3S09A | P3S09A | 860 | S09 | 00 | 2SI1890 | 200 | 200 | 400 | P | LND | 0 | P | S | PS21 | LUZ2 | P | LND | DEV |
| P3S06C |  | S06 Sprinkler System - Eval./Negotiation |  | 94d | 2009-10-29 A | 2010-03-16 A | P3S06B, E3S0620 FF | 100% |  |  |  |  |  |  |  | P3S06C | P3S06C | 860 | S06 | 00 | 2SI1740 | 200 | 200 | 400 | P | LND | 0 | P | S | PS22 | LUZ2 | P | LND |  |
| P3S07C |  | S07 Deluge System - Eval./Negotiation |  | 87d | 2009-10-29 A | 2010-03-05 A | P3S07B, E3S0720 FF | 100% |  |  |  |  |  |  |  | P3S07C | P3S07C | 860 | S07 | 00 | 2SI1730 | 200 | 200 | 400 | P | LND | 0 | P | S | PS22 | LUZ2 | P | LND |  |
| P3S09B |  | S09 Minor FF Equipment - RFQ issued | milestone | 0d | 2009-10-30 A | 2009-10-30 A | P3S09A FF | 100% |  |  |  |  |  | 5,750 | 5,750 | P3S09B | P3S09B | 860 | S09 | 00 | 2SI1890 | 200 | 200 | 400 | P | LND | 0 | P | S | PS21 | LUZ2 | P | LND | DEV |
| P3S10C |  | S10 Flame Arrestors - Eval./Negotiation |  | 45d | 2009-12-28 A | 2010-03-02 A | P3S10B, E3S1020 FF | 100% |  |  |  |  |  |  |  | P3S10C | P3S10C | 860 | S10 | 00 | 2SI1880 | 200 | 200 | 400 | P | LND | 0 | P | S | PS22 | LUZ2 | P | LND |  |
| P3S05C |  | S05 Gas Exting. Syst. - Eval./Negotiation |  | 209d | 2010-01-18 A | 2010-11-10 A | E3S0520 FF, E3S0550 FF, P3S05B | 100% |  |  |  |  |  |  |  | P3S05C | P3S05C | 860 | S05 | 00 | 2SI1770 | 200 | 200 | 400 | P | LND | 0 | P | S | PS22 | LUZ2 | P | LND |  |
| P3S10F |  | S10 Flame Arrestors - Bid tab Client appr. |  | 5d | 2010-01-20 A | 2010-01-26 A | E3S1030 | 100% |  |  |  |  |  |  |  | P3S10F | P3S10F | 860 | S10 | 00 | 2SI1880 | 200 | 200 | 400 | P | PMT | 0 | P | S | PS22 | LUZ2 | P | LND |  |
| P3S06F |  | S06 Sprinkler System - Bid tab Client appr. |  | 5d | 2010-01-25 A | 2010-01-29 A | E3S0630 | 100% |  |  |  |  |  |  |  | P3S06F | P3S06F | 860 | S06 | 00 | 2SI1740 | 200 | 200 | 400 | P | PMT | 0 | P | S | PS22 | LUZ2 | P | PMT |  |
| P3S07F |  | S07 Deluge System - Bid tab Client appr. |  | 5d | 2010-01-25 A | 2010-01-29 A | E3S0730 | 100% |  |  |  |  |  |  |  | P3S07F | P3S07F | 860 | S07 | 00 | 2SI1730 | 200 | 200 | 400 | P | PMT | 0 | P | S | PS22 | LUZ2 | P | PMT |  |
| P3S08BF |  | S08B Monitors - Bid tab Client appr. |  | 5d | 2010-02-01 A | 2010-02-05 A | E3S08B30 | 100% |  |  |  |  |  |  |  | P3S08BF | P3S08BF | 860 | S08B | 00 | 2SI1930 | 200 | 200 | 400 | P | PMT | 0 | P | S | PS22 | LUZ2 | P | LND |  |
| P3S09C |  | S09 Minor FF Equipment - Eval./Negotiation |  | 208d | 2010-02-01 A | 2010-11-24 A | P3S09B, E3S0920 FF | 100% |  |  |  |  |  |  |  | P3S09C | P3S09C | 860 | S09 | 00 | 2SI1890 | 200 | 200 | 400 | P | LND | 0 | P | S | PS22 | LUZ2 | P | LND |  |
| P3S10D |  | S10 Flame Arrestors - PO issued | milestone | 0d | 2010-03-02 A | 2010-03-02 A | HPS30 FF, P3S10F FF, E3S1030 FF, P3S10C FF | 100% |  |  |  |  |  |  |  | P3S10D | P3S10D | 860 | S10 | 00 | 2SI1880 | 200 | 200 | 400 | P | LND | 0 | P | S | PS23 | LUZ2 | P | LND |  |
| P3S10L |  | S10 Flame Arrestors - Lead Time/Fabrication |  | 296d | 2010-03-03 A | 2010-12-24 A | P3S10D | 100% |  |  |  |  | TB26 - 2 - Manuf and Delivy |  |  | P3S10L | P3S10L | 860 | S10 | 00 | 2SI1880 | 200 | 200 | 400 | P | LND | 0 | P | S | PS26 | LUZ2 | P | LND | DEL |
| P3S07D |  | S07 Deluge System - PO issued | milestone | 0d | 2010-03-05 A | 2010-03-05 A | E3S0730 FF, P3S07C FF, P3S07F FF | 100% |  |  |  |  |  | 128,750 | 128,750 | P3S07D | P3S07D | 860 | S07 | 00 | 2SI1730 | 200 | 200 | 400 | P | LND | C5 | P | S | PS23 | LUZ2 | P | LND |  |
| P3S07L |  | S07 Deluge System - Lead Time/Fabrication |  | 349d | 2010-03-06 A | 2011-02-21 A | P3S07D | 100% |  |  |  |  | TB26 - 2 - Manuf and Delivy |  |  | P3S07L | P3S07L | 860 | S07 | 00 | 2SI1730 | 200 | 200 | 400 | P | LND | 0 | P | S | PS26 | LUZ2 | P | LND | DEL |
| HPS30 |  | Issue Equipment PO's | level of effort | 182d | 2010-03-08 A | 2010-11-23 A | P3S07L SS | 100% |  |  |  |  |  |  |  | HPS30 | HPS30 | 871 |  | 00 |  | 200 | 200 | 400 | E | LND | L2 | P | S | PS23 | LUZ2 | P | LND |  |
| HPSS07 |  | Deluge System (S07) PO/Fabr./Transport to Site | level of effort | 368d | 2010-03-08 A | 2011-08-12 A | P3S07L SS | 100% |  |  |  |  |  |  |  | HPSS07 | HPSS07 | 871 |  | 00 |  | 200 | 200 | 400 | E | LND | L2 | P | S | PS23 | LUZ2 | P | LND |  |
| P3S08BC |  | S08B Monitors - Eval./Negotiation |  | 57d | 2010-03-08 A | 2010-05-31 A | E3S08B20 FF | 100% |  |  |  |  |  |  |  | P3S08BC | P3S08BC | 860 | S08B | 00 | 2SI1930 | 200 | 200 | 400 | P | LND | 0 | P | S | PS22 | LUZ2 | P | LND |  |
| P3S06D |  | S06 Sprinkler System - PO issued | milestone | 0d | 2010-03-16 A | 2010-03-16 A | P3S06C FF, P3S06F FF | 100% |  |  |  |  |  | 128,750 | 128,750 | P3S06D | P3S06D | 860 | S06 | 00 | 2SI1740 | 200 | 200 | 400 | P | LND |  | P | S | PS23 | LUZ2 | P | LND |  |
| HPSS06 |  | Sprinkler System(S06) PO/Fabr./Transport to Site | level of effort | 361d | 2010-03-17 A | 2011-08-12 A | P3S06L SS | 100% |  |  |  |  |  |  |  | HPSS06 | HPSS06 | 871 |  | 00 |  | 200 | 200 | 400 | E | LND | L2 | P | S | PS23 | LUZ2 | P | LND |  |
| P3S06L |  | S06 Sprinkler System - Lead Time/Fabrication |  | 338d | 2010-03-17 A | 2011-02-21 A | P3S06D | 100% |  |  |  |  | TB26 - 2 - Manuf and Delivy |  |  | P3S06L | P3S06L | 860 | S06 | 00 | 2SI1740 | 200 | 200 | 400 | P | LND | 0 | P | S | PS26 | LUZ2 | P | LND | DEL |
| P3S01D |  | S01 Safety Relief Valves - 1st PO issued | milestone | 0d | 2010-03-17 A | 2010-03-17 A | P3S01F FF, E3S0130 FF, P3S01C FF | 100% |  |  |  |  |  | 162,750 | 162,750 | P3S01D | P3S01D | 860 | S01 | 00 | 2SI1760 | 200 | 200 | 400 | P | LND | 0 | P | S | PS23 | LUZ2 | P | LND |  |
| HPSS01 |  | Safety R.Valves (S01) PO/Fabr./Transport to Site | level of effort | 362d | 2010-03-18 A | 2011-08-16 A | P3S01L SS | 100% |  |  |  |  |  |  |  | HPSS01 | HPSS01 | 871 |  | 00 |  | 200 | 200 | 400 | E | LND | L2 | P | S | PS23 | LUZ2 | P | LND |  |
| P3S01L |  | S01 Safety Relief Valves - Lead Time/Fabrication |  | 313d | 2010-03-18 A | 2011-01-28 A | P3S01D | 100% |  |  |  |  | TB26 - 2 - Manuf and Delivy |  |  | P3S01L | P3S01L | 860 | S01 | 00 | 2SI1760 | 200 | 200 | 400 | P | LND | 0 | P | S | PS26 | LUZ2 | P | LND | DEL |
| P3S02D |  | S02 Rupture Disks - 1st PO issued | milestone | 0d | 2010-04-20 A | 2010-04-20 A | P3S02C FF, HPS30 FF, E3S0230 FF, P3S02F FF | 100% |  |  |  |  |  | 17,500 | 17,500 | P3S02D | P3S02D | 860 | S02 | 00 | 2SI1750 | 200 | 200 | 400 | P | LND | 0 | P | S | PS23 | LUZ2 | P | LND |  |
| HPSS02 |  | Rupture Disks (S02) PO/Fabr./Transport to Site | level of effort | 384d | 2010-04-21 A | 2011-10-18 | P3S02L SS |  | 33d | -5d | 0d |  |  |  |  | HPSS02 | HPSS02 | 871 |  | 00 |  | 200 | 200 | 400 | E | LND | L2 | P | S | PS23 | LUZ2 | P | LND |  |
| P3S02L |  | S02 Rupture Disks - Lead Time/Fabrication |  | 268d | 2010-04-21 A | 2011-01-17 A | P3S02D | 100% |  |  |  |  | TB26 - 2 - Manuf and Delivy |  |  | P3S02L | P3S02L | 860 | S02 | 00 | 2SI1750 | 200 | 200 | 400 | P | LND | 0 | P | S | PS26 | LUZ2 | P | LND | DEL |
| P3S07G |  | S07 Gost R Certificate to russ. customs | milestone | 0d | 2010-05-28 A | 2010-05-28 A | P3S07N FF-90d | 100% |  |  |  |  | TB26 - 2 - Manuf and Delivy |  |  | P3S07G | P3S07G | 860 | S07 | 00 | 2SI1730 | 200 | 200 | 400 | P | LND | 0 | P | S | PS28 | LUZ2 | P | LND |  |
| P3S08BD |  | S08B Monitors - PO issued | milestone | 0d | 2010-05-31 A | 2010-05-31 A | E3S08B30 FF, P3S08BC FF+5d, P3S08BF FF | 100% |  |  |  |  |  | 48,250 | 48,250 | P3S08BD | P3S08BD | 860 | S08B | 00 | 2SI1930 | 200 | 200 | 400 | P | LND | 0 | P | S | PS23 | LUZ2 | P | LND |  |
| P3S08BL |  | S08B Monitors - Lead Time/Fabrication |  | 235d | 2010-06-01 A | 2011-01-24 A | P3S08BD | 100% |  |  |  |  | TB26 - 2 - Manuf and Delivy |  |  | P3S08BL | P3S08BL | 860 | S08B | 00 | 2SI1930 | 200 | 200 | 400 | P | LND | 0 | P | S | PS26 | LUZ2 | P | LND | DEL |
| P3S08F |  | S08A Hydrants - Bid tab Client appr. |  | 5d | 2010-06-04 A | 2010-06-10 A | E3S0830 | 100% |  |  |  |  |  |  |  | P3S08F | P3S08F | 860 | S08A | 00 | 2SI1810 | 200 | 200 | 400 | P | PMT | 0 | P | S | PS22 | LUZ2 | P | PMT |  |
| P3S08D |  | S08A Hydrants - PO issued | milestone | 0d | 2010-06-17 A | 2010-06-17 A | P3S08F FF, AD1350, P3S08C FF+5d, E3S0830 FF | 100% |  |  |  |  |  | 48,250 | 48,250 | P3S08D | P3S08D | 860 | S08A | 00 | 2SI1810 | 200 | 200 | 400 | P | LND | 0 | P | S | PS23 | LUZ2 | P | LND |  |
| HPSS08 |  | Hydrant&Monitor (S08) PO/Fabr./Transport to Site | level of effort | 198d | 2010-06-18 A | 2011-03-25 A | P3S08L SS | 100% |  |  |  |  |  |  |  | HPSS08 | HPSS08 | 871 |  | 00 |  | 200 | 200 | 400 | E | LND | L2 | P | S | PS23 | LUZ2 | P | LND |  |
| P3S08L |  | S08A Hydrants - Lead Time/Fabrication |  | 218d | 2010-06-18 A | 2011-01-24 A | P3S08D | 100% |  |  |  |  | TB26 - 2 - Manuf and Delivy |  |  | P3S08L | P3S08L | 860 | S08A | 00 | 2SI1810 | 200 | 200 | 400 | P | LND | 0 | P | S | PS26 | LUZ2 | P | LND | DEL |
| P3S10G |  | S10 Gost R Certificate to russ. customs | milestone | 0d | 2010-09-27 A | 2010-09-27 A | P3S10N FF-90d | 100% |  |  |  |  | TB26 - 2 - Manuf and Delivy |  |  | P3S10G | P3S10G | 860 | S10 | 00 | 2SI1880 | 200 | 200 | 400 | P | LND | 0 | P | S | PS28 | LUZ2 | P | LND |  |

Notes:
- P3J03N: P3 Activity Log Info: 30days delivery time, / 30days custom clearance
- P3S06B: Expenses: 900A 25750
- P3S07B: Expenses: 900A 25750
- P3S01B: Expenses: 900A 32550
- P3S02B: Expenses: 900A 3500
- P3S05B: Expenses: 900A 24500
- P3S08B: Expenses: 900A 19300
- P3S09B: Expenses: 900A 5750
- P3S07D: Expenses: 900A 128750
- HPS30: UDF_Actictity Name (Russia): Выпуск заказов на поставку оборудования
- HPSS07: UDF_Actictity Name (Russia): Дренчерная система (S07), заказ на поставку/изготовление/транспортировка на площадку
- P3S06D: Expenses: 900A 128750
- HPSS06: UDF_Actictity Name (Russia): Спринклерная система (S06), заказ на поставку/изготовление/транспортировка на площадку
- P3S01D: Expenses: 900A 162750
- HPSS01: UDF_Actictity Name (Russia): Предохранительные клапаны (S01), заказ на поставку/изготовление/транспортировка на площадку
- P3S02D: Expenses: 900A 17500
- HPSS02: UDF_Actictity Name (Russia): Разрывные мембраны (S02), заказ на поставку/изготовление/транспортировка на площадку
- P3S08BD: Expenses: 900A 48250
- P3S08D: Expenses: 900A 48250
- HPSS08: UDF_Actictity Name (Russia): Гидранты и лафеты (S08), заказ на поставку/изготовление/транспортировка на площадку

| ID | Activity | Type | Duration | Start | Finish | Predecessors | Complete | Remaining | Total float | Free float | Constraint | Calendar | Cost | Actual cost | UDF_SAVE ACTID | UDF_SAVE ACT ID | Department | Type of Work | Constr. Area | Inquiry/Order No | PMT-Area | PMT-Schedule Org | PMT-Discipline | PMT-Phase | PMT-Respons. | Zeigen/n. Zeigen | WBS Phase | WBS Discipline | WBS Type of Work | WBS Objects | IMS | UPT | PMT-Doc. Type |
| --- | --- | --- | --- | --- | --- | --- | --- | --- | --- | --- | --- | --- | --- | --- | --- | --- | --- | --- | --- | --- | --- | --- | --- | --- | --- | --- | --- | --- | --- | --- | --- | --- | --- |
| P3S09F | S09 Minor FF Equipment - Bid tab Client appr. |  | 14d | 2010-10-18 A | 2010-11-04 A | E3S0930 | 100% |  |  |  |  |  |  |  | P3S09F | P3S09F | 860 | S09 | 00 | 2SI1890 | 200 | 200 | 400 | P | PMT | 0 | P | S | PS22 | LUZ2 | P | PMT |  |
| P3S05F | S05 Gas Exting. Syst. - Bid tab Client appr. |  | 6d | 2010-10-27 A | 2010-11-03 A | E3S0530 | 100% |  |  |  |  |  |  |  | P3S05F | P3S05F | 860 | S05 | 00 | 2SI1770 | 200 | 200 | 400 | P | PMT | 0 | P | S | PS22 | LUZ2 | P | PMT |  |
| P3S05D | S05 Gas Exting. Syst. - PO issued (Hardware) | milestone | 0d | 2010-11-10 A | 2010-11-10 A | P3S05C FF, P3S05F | 100% |  |  |  |  |  | 122,500 | 122,500 | P3S05D | P3S05D | 860 | S05 | 00 | 2SI1770 | 200 | 200 | 400 | P | LND | 0 | P | S | PS23 | LUZ2 | P | LND |  |
| HPSS05 | Gas Ext.System (S05) PO/Fabr./Transport to Site | level of effort | 243d | 2010-11-11 A | 2011-10-21 | P3S05L SS |  | 36d | -1d | 0d |  |  |  |  | HPSS05 | HPSS05 | 871 |  | 00 |  | 200 | 200 | 400 | E | LND | L2 | P | S | PS23 | LUZ2 | P | LND |  |
| P3S05L | S05 Gas Exting. Syst. - Lead Time/Fabrication |  | 236d | 2010-11-11 A | 2011-07-08 A | P3S05D | 100% |  |  |  |  | TB26 - 2 - Manuf and Delivy |  |  | P3S05L | P3S05L | 860 | S05 | 00 | 2SI1770 | 200 | 200 | 400 | P | LND | 0 | P | S | PS26 | LUZ2 | P | LND | DEL |
| P3S09D | S09 Minor FF Equipment - PO issued | milestone | 0d | 2010-11-24 A | 2010-11-24 A | HPS30 FF, P3S09F FF, E3S0930 FF, P3S09C FF | 100% |  |  |  |  |  | 28,750 | 28,750 | P3S09D | P3S09D | 860 | S09 | 00 | 2SI1890 | 200 | 200 | 400 | P | LND | 0 | P | S | PS23 | LUZ2 | P | LND |  |
| HPSS09 | Minor Fire Fighting Eqpt. (S09) PO/Fabr./Transport to Site | level of effort | 229d | 2010-11-25 A | 2011-10-14 | P3S09L SS |  | 31d | 39.88d | 0d |  |  |  |  | HPSS09 | HPSS09 | 871 |  | 00 |  | 200 | 200 | 400 | E | LND | L2 | P | S | PS23 | LUZ2 | P | LND |  |
| P3S09L | S09 Minor FF Equipment - Lead Time/Fabrication |  | 201d | 2010-11-25 A | 2011-06-17 A | P3S09D | 100% |  |  |  |  | TB26 - 2 - Manuf and Delivy |  |  | P3S09L | P3S09L | 860 | S09 | 00 | 2SI1890 | 200 | 200 | 400 | P | LND | 0 | P | S | PS26 | LUZ2 | P | LND | DEL |
| P3S01G | S01 Gost R Certificate to russ. customs | milestone | 0d | 2010-12-01 A | 2010-12-01 A | P3S01N FF-90d | 100% |  |  |  |  | TB26 - 2 - Manuf and Delivy |  |  | P3S01G | P3S01G | 860 | S01 | 00 | 2SI1760 | 200 | 200 | 400 | P | LND | 0 | P | S | PS28 | LUZ2 | P | LND |  |
| P3S02G | S02 Gost R Certificate to russ. customs | milestone | 0d | 2010-12-11 A | 2010-12-11 A | P3S02N FF-90d | 100% |  |  |  |  | TB26 - 2 - Manuf and Delivy |  |  | P3S02G | P3S02G | 860 | S02 | 00 | 2SI1750 | 200 | 200 | 400 | P | LND | 0 | P | S | PS28 | LUZ2 | P | LND |  |
| P3S08BX | S08B Monitors - Final Inspection | milestone | 0d | 2010-12-14 A | 2010-12-14 A | P3S08BL FF-10d | 100% |  |  |  |  | TB26 - 2 - Manuf and Delivy | 86,850 | 86,850 | P3S08BX | P3S08BX | 860 | S08B | 00 | 2SI1930 | 200 | 200 | 400 | P | LND | 0 | P | S | PS27 | LUZ2 | P | LND |  |
| P3S10X | S10 Flame Arrestors - Final Inspection | milestone | 0d | 2010-12-20 A | 2010-12-20 A | P3S10L FF-5d | 100% |  |  |  |  | TB26 - 2 - Manuf and Delivy |  |  | P3S10X | P3S10X | 860 | S10 | 00 | 2SI1880 | 200 | 200 | 400 | P | LND | 0 | P | S | PS27 | LUZ2 | P | LND |  |
| P3S08X | S08A Hydrants - Final Inspection | milestone | 0d | 2010-12-30 A | 2010-12-30 A | P3S08L FF-5d | 100% |  |  |  |  | TB26 - 2 - Manuf and Delivy | 86,850 | 86,850 | P3S08X | P3S08X | 860 | S08A | 00 | 2SI1810 | 200 | 200 | 400 | P | LND | 0 | P | S | PS27 | LUZ2 | P | LND |  |
| P3S10M | S10 Flame Arrestors - Goods deliv. FCA/FOB | milestone | 0d | 2010-12-31 A | 2010-12-31 A | P3S10X FF, P3S10L FF+5d | 100% |  |  |  |  | TB26 - 2 - Manuf and Delivy |  |  | P3S10M | P3S10M | 860 | S10 | 00 | 2SI1880 | 200 | 200 | 400 | P | LND | 0 | P | S | PS28 | LUZ2 | P | LND |  |
| P3S02X | S02 Rupture Disks - Final Inspection | milestone | 0d | 2011-01-06 A | 2011-01-06 A | P3S02L FF-12d | 100% |  |  |  |  | TB26 - 2 - Manuf and Delivy | 31,500 | 31,500 | P3S02X | P3S02X | 860 | S02 | 00 | 2SI1750 | 200 | 200 | 400 | P | LND | 0 | P | S | PS27 | LUZ2 | P | LND |  |
| P3S06G | S06 Gost R Certificate to russ. customs | milestone | 0d | 2011-01-08 A | 2011-01-08 A | P3S06N FF-90d | 100% |  |  |  |  | TB26 - 2 - Manuf and Delivy |  |  | P3S06G | P3S06G | 860 | S06 | 00 | 2SI1740 | 200 | 200 | 400 | P | LND | 0 | P | S | PS28 | LUZ2 | P | LND |  |
| P3S01X | S01 Safety Relief Valves - Final Inspection | milestone | 0d | 2011-01-19 A | 2011-01-19 A | P3S01L FF-10d | 100% |  |  |  |  | TB26 - 2 - Manuf and Delivy | 292,950 | 292,950 | P3S01X | P3S01X | 860 | S01 | 00 | 2SI1760 | 200 | 200 | 400 | P | LND | 0 | P | S | PS27 | LUZ2 | P | LND |  |
| P3S02M | S02 Rupture Disks - Goods deliv. FCA/FOB | milestone | 0d | 2011-01-22 A | 2011-01-22 A | P3S02L FF+5d, P3S02X FF | 100% |  |  |  |  | TB26 - 2 - Manuf and Delivy | 10,500 | 10,500 | P3S02M | P3S02M | 860 | S02 | 00 | 2SI1750 | 200 | 200 | 400 | P | LND | 0 | P | S | PS28 | LUZ2 | P | LND |  |
| P3S08BM | S08B Monitors - Goods deliv. FOB | milestone | 0d | 2011-01-24 A | 2011-01-24 A | P3S08BX FF, P3S08BL FF | 100% |  |  |  |  | TB26 - 2 - Manuf and Delivy | 28,950 | 28,950 | P3S08BM | P3S08BM | 860 | S08B | 00 | 2SI1930 | 200 | 200 | 400 | P | LND | 0 | P | S | PS28 | LUZ2 | P | LND |  |
| P3S08M | S08A Hydrants - Goods deliv. FOB | milestone | 0d | 2011-01-24 A | 2011-01-24 A | P3S08X FF, P3S08L FF | 100% |  |  |  |  | TB26 - 2 - Manuf and Delivy | 28,950 | 28,950 | P3S08M | P3S08M | 860 | S08A | 00 | 2SI1810 | 200 | 200 | 400 | P | LND | 0 | P | S | PS28 | LUZ2 | P | LND |  |
| P3S01M | S01 Safety Relief Valves - Goods deliv. FOB | milestone | 0d | 2011-01-28 A | 2011-01-28 A | P3S01X FF, P3S01L FF | 100% |  |  |  |  | TB26 - 2 - Manuf and Delivy | 97,650 | 97,650 | P3S01M | P3S01M | 860 | S01 | 00 | 2SI1760 | 200 | 200 | 400 | P | LND | 0 | P | S | PS28 | LUZ2 | P | LND |  |
| P3S06X | S06 Sprinkler System - Final Inspection | milestone | 0d | 2011-02-07 A | 2011-02-07 A | P3S06D, P3S06L FF-15d | 100% |  |  |  |  | TB26 - 2 - Manuf and Delivy | 231,750 | 231,750 | P3S06X | P3S06X | 860 | S06 | 00 | 2SI1740 | 200 | 200 | 400 | P | LND | 0 | P | S | PS27 | LUZ2 | P | LND |  |
| P3S07X | S07 Deluge System - Final Inspection | milestone | 0d | 2011-02-07 A | 2011-02-07 A | P3S07L FF-15d | 100% |  |  |  |  | TB26 - 2 - Manuf and Delivy | 231,750 | 231,750 | P3S07X | P3S07X | 860 | S07 | 00 | 2SI1730 | 200 | 200 | 400 | P | LND | 0 | P | S | PS27 | LUZ2 | P | LND |  |
| P3S06M | S06 Sprinkler System - Goods deliv. FOB | milestone | 0d | 2011-02-26 A | 2011-02-26 A | P3S06L FF+5d, P3S06X FF | 100% |  |  |  |  | TB26 - 2 - Manuf and Delivy | 77,250 | 77,250 | P3S06M | P3S06M | 860 | S06 | 00 | 2SI1740 | 200 | 200 | 400 | P | LND | 0 | P | S | PS28 | LUZ2 | P | LND |  |
| P3S07M | S07 Deluge System - Goods deliv. FOB | milestone | 0d | 2011-02-26 A | 2011-02-26 A | P3S07X FF, P3S07L FF+5d | 100% |  |  |  |  | TB26 - 2 - Manuf and Delivy | 77,250 | 77,250 | P3S07M | P3S07M | 860 | S07 | 00 | 2SI1730 | 200 | 200 | 400 | P | LND | 0 | P | S | PS28 | LUZ2 | P | LND |  |
| P3S08BN | S08B Monitors - Transport to Site (CIF Rail Station Tobolsk) |  | 20d | 2011-03-07 A | 2011-03-26 A | P3S08BM | 100% |  |  |  | start on 2011-03-07 | TB26 - 2 - Manuf and Delivy |  |  | P3S08BN | P3S08BN | 860 | S08B | 00 | 2SI1930 | 200 | 200 | 400 | P | LND | 0 | P | S | PS28 | LUZ2 | P | LND |  |
| P3S08N | S08A Hydrants - Transport to Site |  | 20d | 2011-03-07 A | 2011-03-26 A | P3S08M | 100% |  |  |  | start on 2011-03-07 | TB26 - 2 - Manuf and Delivy |  |  | P3S08N | P3S08N | 860 | S08A | 00 | 2SI1810 | 200 | 200 | 400 | P | LND | 0 | P | S | PS28 | LUZ2 | P | LND |  |
| P3S09G | S09 Gost R Certificate to russ. customs | milestone | 0d | 2011-04-01 A | 2011-04-01 A | P3S09N FF-90d | 100% |  |  |  |  | TB26 - 2 - Manuf and Delivy |  |  | P3S09G | P3S09G | 860 | S09 | 00 | 2SI1890 | 200 | 200 | 400 | P | LND | 0 | P | S | PS28 | LUZ2 | P | LND |  |
| P3S05G | S05 Gost R Certificate to russ. customs | milestone | 0d | 2011-04-16 A | 2011-04-16 A | P3S05N FF-90d | 100% |  |  |  |  | TB26 - 2 - Manuf and Delivy |  |  | P3S05G | P3S05G | 860 | S05 | 00 | 2SI1770 | 200 | 200 | 400 | P | LND | 0 | P | S | PS28 | LUZ2 | P | LND |  |
| P3S09X | S09 Minor FF Equipment - Final Inspection | milestone | 0d | 2011-05-22 A | 2011-05-22 A | P3S09L FF-10d | 100% |  |  |  |  | TB26 - 2 - Manuf and Delivy | 51,750 | 51,750 | P3S09X | P3S09X | 860 | S09 | 00 | 2SI1890 | 200 | 200 | 400 | P | LND | 0 | P | S | PS27 | LUZ2 | P | LND |  |
| P3S09M | S09 Minor FF Equipment - Goods deliv. FOB/EXW | milestone | 0d | 2011-06-27 A | 2011-06-27 A | P3S09X FF, P3S09L FF+10d | 100% |  |  |  |  | TB26 - 2 - Manuf and Delivy | 17,250 | 17,250 | P3S09M | P3S09M | 860 | S09 | 00 | 2SI1890 | 200 | 200 | 400 | P | LND | 0 | P | S | PS28 | LUZ2 | P | LND |  |
| P3S05X | S05 Gas Exting. Syst. - Final Inspection | milestone | 0d | 2011-06-28 A | 2011-06-28 A | P3S05L FF-11d | 100% |  |  |  |  | TB26 - 2 - Manuf and Delivy | 220,500 | 220,500 | P3S05X | P3S05X | 860 | S05 | 00 | 2SI1770 | 200 | 200 | 400 | P | LND | 0 | P | S | PS27 | LUZ2 | P | LND |  |
| P3S06N | S06 Sprinkler System - Transport to Site (transport when temp. degree above zero) |  | 26d | 2011-07-18 A | 2011-08-12 A | P3S06M FS+15d | 100% |  |  |  | start on 2011-07-18 | TB26 - 2 - Manuf and Delivy |  |  | P3S06N | P3S06N | 860 | S06 | 00 | 2SI1740 | 200 | 200 | 400 | P | LND | 0 | P | S | PS28 | LUZ2 | P | LND |  |
| P3S07N | S07 Deluge System - Transport to Site (transport when temp. degree above zero) |  | 26d | 2011-07-18 A | 2011-08-12 A | P3S07M FS+15d | 100% |  |  |  | start on 2011-07-18 | TB26 - 2 - Manuf and Delivy |  |  | P3S07N | P3S07N | 860 | S07 | 00 | 2SI1730 | 200 | 200 | 400 | P | LND | 0 | P | S | PS28 | LUZ2 | P | LND |  |
| P3S05M | S05 Gas Exting. Syst. - Goods deliv. FOB/EXW | milestone | 0d | 2011-07-18 A | 2011-07-18 A | P3S05X FF, P3S05L FF+10d | 100% |  |  |  |  | TB26 - 2 - Manuf and Delivy | 73,500 | 73,500 | P3S05M | P3S05M | 860 | S05 | 00 | 2SI1770 | 200 | 200 | 400 | P | LND | 0 | P | S | PS28 | LUZ2 | P | LND |  |
| P3S01N | S01 Safety Relief Valves - Transport to Site |  | 22d | 2011-07-26 A | 2011-08-16 A | P3S01M FS+20d | 100% |  |  |  |  | TB26 - 2 - Manuf and Delivy |  |  | P3S01N | P3S01N | 860 | S01 | 00 | 2SI1760 | 200 | 200 | 400 | P | LND | 0 | P | S | PS28 | LUZ2 | P | LND |  |
| P3S02N | S02 Rupture Disks - Transport to Site (collection of div. packages) |  | 30d | 2011-09-19 | 2011-10-18 | P3S02M |  |  | -7d | 0d | start on or after 2011-09-19 | TB26 - 2 - Manuf and Delivy |  |  | P3S02N | P3S02N | 860 | S02 | 00 | 2SI1750 | 200 | 200 | 400 | P | LND | 0 | P | S | PS28 | LUZ2 | P | LND |  |
| P3S10N | S10 Flame Arrestors - Transport to Site (collection of div. packages) |  | 30d | 2011-09-19 | 2011-10-18 | P3S10M |  |  | -63d | 0d | start on or after 2011-09-19 | TB26 - 2 - Manuf and Delivy |  |  | P3S10N | P3S10N | 860 | S10 | 00 | 2SI1880 | 200 | 200 | 400 | P | LND | 0 | P | S | PS28 | LUZ2 | P | LND |  |
| P3S05N | S05 Gas Exting. Syst. - Transport to Site |  | 30d | 2011-09-22 | 2011-10-21 | P3S05M FS+65d |  |  | -1d | 0d |  | TB26 - 2 - Manuf and Delivy |  |  | P3S05N | P3S05N | 860 | S05 | 00 | 2SI1770 | 200 | 200 | 400 | P | LND | 0 | P | S | PS28 | LUZ2 | P | LND |  |
| P3S09N | S09 Minor FF Equipment - Transport to Site |  | 20d | 2011-09-25 | 2011-10-14 | P3S09M FS+90d |  |  | 58.88d | 0d |  | TB26 - 2 - Manuf and Delivy |  |  | P3S09N | P3S09N | 860 | S09 | 00 | 2SI1890 | 200 | 200 | 400 | P | LND | 0 | P | S | PS28 | LUZ2 | P | LND |  |

Notes:
- P3S05D: Expenses: 900A 122500
- HPSS05: UDF_Actictity Name (Russia): Система газового пожаротушения (S05), заказ на поставку/изготовление/транспортировка на площадку
- P3S09D: Expenses: 900A 28750
- HPSS09: UDF_Actictity Name (Russia): Гидранты и лафеты (S08), заказ на поставку/изготовление/транспортировка на площадку
- P3S08BX: Expenses: 900A 86850
- P3S08X: Expenses: 900A 86850
- P3S02X: Expenses: 900A 31500
- P3S01X: Expenses: 900A 292950
- P3S02M: Expenses: 900A 10500
- P3S08BM: Expenses: 900A 28950
- P3S08M: Expenses: 900A 28950
- P3S01M: Expenses: 900A 97650
- P3S06X: Expenses: 900A 231750
- P3S07X: Expenses: 900A 231750
- P3S06M: Expenses: 900A 77250
- P3S07M: Expenses: 900A 77250
- P3S09X: Expenses: 900A 51750
- P3S09M: Expenses: 900A 17250
- P3S05X: Expenses: 900A 220500
- P3S05M: Expenses: 900A 73500

| ID | WBS | Activity | Type | Duration | Start | Finish | Predecessors | Complete | Total float | Free float | Calendar | Cost | Actual cost | UDF_SAVE ACTID | UDF_SAVE ACT ID | Department | Type of Work | Constr. Area | Inquiry/Order No | PMT-Area | PMT-Schedule Org | PMT-Discipline | PMT-Phase | PMT-Doc. Type | PMT-Respons. | Zeigen/n. Zeigen | WBS Phase | WBS Discipline | WBS Type of Work | WBS Objects | IMS | UPT |
| --- | --- | --- | --- | --- | --- | --- | --- | --- | --- | --- | --- | --- | --- | --- | --- | --- | --- | --- | --- | --- | --- | --- | --- | --- | --- | --- | --- | --- | --- | --- | --- | --- |
|  | 0000 | **0000 Generals - all CA's** |  |  | 2010-07-01 | 2012-01-12 |  |  |  |  |  |  |  |  |  |  |  |  |  |  |  |  |  |  |  |  |  |  |  |  |  |  |
|  | N | **N Structural Steel** |  |  | 2010-07-01 | 2010-11-30 |  |  |  |  |  |  |  |  |  |  |  |  |  |  |  |  |  |  |  |  |  |  |  |  |  |  |
| P3N03L |  | N01 Structural Steel Fab - Lead Time/Fabrication |  | 148d | 2010-07-01 A | 2010-11-25 A | P3N01D | 100% |  |  | TB26 - 2 - Manuf and Delivy |  |  | P3N03L | P3N03L | 860 | N01 | 00 | 2M00020 | 200 | 200 | 400 | P | DEL | Chel | 0 | P | N | PN26 | 0000 | SS | LND |
| P3N03P |  | N01 Structural Steel Fab - Transport to Site |  | 5d | 2010-11-26 A | 2010-11-30 A | P3N03L | 100% |  |  | TB26 - 2 - Manuf and Delivy |  |  | P3N03P | P3N03P | 860 | N01 | 00 | 2M00020 | 200 | 200 | 400 | P |  | Chel | 0 | P | N | PN28 | 0000 | SS | LND |
| P3N03N |  | N01 Structural Steel Fab - 1st Goods arrived at Site | milestone | 0d | 2010-11-30 A | 2010-11-30 A | P3N03P FF | 100% |  |  | TB26 - 2 - Manuf and Delivy |  |  | P3N03N | P3N03N | 860 | N01 | 00 | 2M00020 | 200 | 200 | 400 | P |  | Chel | L2 | P | N | PN29 | 0000 | SS | LND |
|  | R | **R Piping** |  |  | 2010-10-12 | 2012-01-12 |  |  |  |  |  |  |  |  |  |  |  |  |  |  |  |  |  |  |  |  |  |  |  |  |  |  |
| P3R06BS |  | R06B AG Pipes CS - Material arrived at Site |  | 179d | 2010-10-12 A | 2011-04-11 A | HPRR06B FF, IMS-P-000120 (other project) FF, P3R06BN FF | 100% |  |  | TB26 - 2 - Manuf and Delivy |  |  | P3R06BS | P3R06BS | 860 | R06B | 00 | 2RE1800 | 200 | 200 | 400 | P |  | OWN | 0 | P | R | PR29 | 0000 | AG | LND |
| P3R06BS1 |  | R06B AG Pipes CS - 1st Mat. arr. at Site | milestone | 0d | 2010-10-12 A | 2010-10-12 A | XR400C10 (other project), P3R06BS SF+1d | 100% |  |  | TB26 - 2 - Manuf and Delivy | 222,021 | 222,021 | P3R06BS1 | P3R06BS1 | 860 | R06B | 00 | 2RE1800 | 200 | 200 | 400 | P |  | OWN | 0 | P | R | PR29 | 0000 | AG | LND |
| P3R06DS |  | R06D AG Flanges CS/SS - Material arrived at Site |  | 164d | 2010-10-17 A | 2011-04-01 A | IMS-P-000120 (other project) FF, P3R06DN FF, HPRR06C FF | 100% |  |  | TB26 - 2 - Manuf and Delivy |  |  | P3R06DS | P3R06DS | 860 | R06D | 00 | 2RE1840 | 200 | 200 | 400 | P |  | OWN | 0 | P | R | PR29 | 0000 | AG | LND |
| P3R06DS1 |  | R06D AG Flanges CS/SS - 1st Mat. arr. at Site | milestone | 0d | 2010-10-17 A | 2010-10-17 A | P3R06DS SF+1d, XR400C10 (other project) | 100% |  |  | TB26 - 2 - Manuf and Delivy | 106,928.5 | 106,928.5 | P3R06DS1 | P3R06DS1 | 860 | R06D | 00 | 2RE1840 | 200 | 200 | 400 | P |  | OWN | 0 | P | R | PR29 | 0000 | AG | LND |
| P3R02AS |  | R02A UG Cast Iron Pipes - Material arrived at Site |  | 265d | 2010-10-21 A | 2011-07-16 A | HPRR02A FF, IMS-P-000110 (other project) FF, P3R02AN FF | 100% |  |  | TB26 - 2 - Manuf and Delivy |  |  | P3R02AS | P3R02AS | 860 | R02A | 00 | 2RE2240 | 200 | 200 | 400 | P |  | OWN | C5 | P | R | PR29 | 0000 | UG | LND |
| P3R02AS1 |  | R02A UG Cast Iron Pipes - 1st Material arrived at Site | milestone | 0d | 2010-10-21 A | 2010-10-21 A | P3R02AG, P3R02AS SF+1d | 100% |  |  | TB26 - 2 - Manuf and Delivy | 93,298 | 93,298 | P3R02AS1 | P3R02AS1 | 860 | R02A | 00 | 2RE2240 | 200 | 200 | 400 | P |  | OWN | C5 | P | R | PR29 | 0000 | UG | LND |
| P3R06S |  | R06 AG Fittings CS - Material arr. at Site |  | 175d | 2010-10-24 A | 2011-04-19 A | P3R06N FF, HPRR06 FF, IMS-P-000120 (other project) FF | 100% |  |  | TB26 - 2 - Manuf and Delivy |  |  | P3R06S | P3R06S | 860 | R06 | 00 | 2RE1820 | 200 | 200 | 400 | P |  | OWN | 0 | P | R | PR29 | 0000 | AG | LND |
| P3R06S1 |  | R06 AG Fittings CS - 1st Mat. arr. at Site | milestone | 0d | 2010-10-24 A | 2010-10-24 A | P3R06S SF+1d, XR400C10 (other project) | 100% |  |  | TB26 - 2 - Manuf and Delivy | 73,259.5 | 73,259.5 | P3R06S1 | P3R06S1 | 860 | R06 | 00 | 2RE1820 | 200 | 200 | 400 | P |  | OWN | 0 | P | R | PR29 | 0000 | AG | LND |
| P3R06AS |  | R06A AG Fittings SS - Material arrived at Site |  | 168d | 2010-10-31 A | 2011-04-19 A | IMS-P-000120 (other project) FF, P3R06AN FF, HPRR06A FF | 100% |  |  | TB26 - 2 - Manuf and Delivy |  |  | P3R06AS | P3R06AS | 860 | R06A | 00 | 2RE1830 | 200 | 200 | 400 | P |  | OWN | 0 | P | R | PR29 | 0000 | AG | LND |
| P3R06AS1 |  | R06A AG Fittings SS - 1st Mat. arr. at Site | milestone | 0d | 2010-10-31 A | 2010-10-31 A | P3R06AS SF+1d | 100% |  |  | TB26 - 2 - Manuf and Delivy | 30,667 | 30,667 | P3R06AS1 | P3R06AS1 | 860 | R06A | 00 | 2RE1830 | 200 | 200 | 400 | P |  | OWN | 0 | P | R | PR29 | 0000 | AG | LND |
| P3R06CS |  | R06C AG Pipes SS - Material arrived at Site |  | 140d | 2010-11-15 A | 2011-04-06 A | P3R06CN FF, HPRR06C FF, IMS-P-000120 (other project) FF | 100% |  |  | TB26 - 2 - Manuf and Delivy |  |  | P3R06CS | P3R06CS | 860 | R06C | 00 | 2RE1810 | 200 | 200 | 400 | P |  | OWN | 0 | P | R | PR29 | 0000 | AG | LND |
| P3R06CS1 |  | R06C AG Pipes SS - 1st Mat. arr. at Site | milestone | 0d | 2010-11-15 A | 2010-11-15 A | P3R06CS SF+1d | 100% |  |  | TB26 - 2 - Manuf and Delivy | 155,748 | 155,748 | P3R06CS1 | P3R06CS1 | 860 | R06C | 00 | 2RE1810 | 200 | 200 | 400 | P |  | OWN | 0 | P | R | PR29 | 0000 | AG | LND |
| P3R02S |  | R02 UG GFK Pipes - Material arrived at Site |  | 115d | 2010-11-17 A | 2011-03-14 A | P3R02N FF, IMS-P-000110 (other project) FF, HPRR02 FF | 100% |  |  | TB26 - 2 - Manuf and Delivy |  |  | P3R02S | P3R02S | 860 | R02 | 00 | 2RE1350 | 200 | 200 | 400 | P |  | OWN | C5 | P | R | PR29 | 0000 | UG | LND |
| P3R02S1 |  | R02 UG GFK Pipes - 1st Material arrived at Site | milestone | 0d | 2010-11-17 A | 2010-11-17 A | P3R02G, P3R02S SF+1d | 100% |  |  | TB26 - 2 - Manuf and Delivy | 93,298 | 93,298 | P3R02S1 | P3R02S1 | 860 | R02 | 00 | 2RE1350 | 200 | 200 | 400 | P |  | OWN | C5 | P | R | PR29 | 0000 | UG | LND |
| P3R07AS |  | R07A Standard Pipe Supp. - Material arrived at Site |  | 178d | 2010-11-21 A | 2011-05-21 A | IMS-P-000120 (other project) FF, P3R07AN FF, HPRR07 FF | 100% |  |  | TB26 - 2 - Manuf and Delivy |  |  | P3R07AS | P3R07AS | 860 | R07A | 00 | 2RE2190 | 200 | 200 | 400 | P |  | OWN | 0 | P | R | PR29 | 0000 | AG | LND |
| P3R07AS1 |  | R07A Standard Pipe Supp. - 1st Material arr. at Site | milestone | 0d | 2010-11-21 A | 2010-11-21 A | P3R07AS SF+1d | 100% |  |  | TB26 - 2 - Manuf and Delivy | 107,843 | 107,843 | P3R07AS1 | P3R07AS1 | 860 | R07A | 00 | 2RE2190 | 200 | 200 | 400 | P |  | OWN | 0 | P | R | PR29 | 0000 | AG | LND |
| P3R04S |  | R04 AG Gate Valves - Material arrived at Site |  | 134d | 2011-01-24 A | 2011-06-07 A | IMS-P-000120 (other project) FF, HPRR04 FF, P3R04N FF | 100% |  |  | TB26 - 2 - Manuf and Delivy |  |  | P3R04S | P3R04S | 860 | R04 | 00 | 2AC2600 | 200 | 200 | 400 | P |  | OWN | 0 | P | R | PR29 | 0000 | AG | LND |
| P3R04S1 |  | R04 AG Gate Valves - 1st Material arr. at Site | milestone | 0d | 2011-01-24 A | 2011-01-24 A | P3R04S SF+1d | 100% |  |  | TB26 - 2 - Manuf and Delivy | 383,932.5 | 383,932.5 | P3R04S1 | P3R04S1 | 860 | R04 | 00 | 2AC2600 | 200 | 200 | 400 | P |  | OWN | 0 | P | R | PR29 | 0000 | AG | LND |
| P3R04AS |  | R04A Piston RAM Valves - Material arr. at Site | milestone | 0d | 2011-03-31 A | 2011-03-31 A | P3R04AN | 100% |  |  | TB26 - 2 - Manuf and Delivy | 20,900 | 20,900 | P3R04AS | P3R04AS | 860 | R04A | 00 | 2AC5490 | 200 | 200 | 400 | P |  | OWN | 0 | P | R | PR29 | 0000 | AG | LND |
| P3R03BS1 |  | R03B Gaskets - 1st Material arrived at Site | milestone | 0d | 2011-04-27 A | 2011-04-27 A | P3R03BN | 100% |  |  | TB26 - 2 - Manuf and Delivy | 16,927 | 16,927 | P3R03BS1 | P3R03BS1 | 860 | R03B | 00 | 2RE2380 | 200 | 200 | 400 | P |  | OWN | 0 | P | R | PR29 | 0000 | AG | LND |
| P3R03AS1 |  | R03 Bolting Mat. - 1st Material arrived at Site | milestone | 0d | 2011-04-29 A | 2011-04-29 A | P3R03AN FF | 100% |  |  | TB26 - 2 - Manuf and Delivy | 37,236 | 37,236 | P3R03AS1 | P3R03AS1 | 860 | R03A | 00 | 2RE2610 | 200 | 200 | 400 | P |  | OWN | 0 | P | R | PR29 | 0000 | AG | LND |
| P3R02BS |  | R02B HDPE Pipes - Material arrived at Site | milestone | 0d | 2011-06-15 A | 2011-06-15 A | P3R02BN | 100% |  |  | TB26 - 2 - Manuf and Delivy |  |  | P3R02BS1 | P3R02BS | 860 | R02B | 00 | 2RE2290 | 200 | 200 | 400 | P |  | OWN | 0 | P | R | PR29 | 0000 | UG | LND |
| P3R01S |  | R01 UG Post Ind. Valves - Goods arrived at Site | milestone | 0d | 2011-10-06 | 2011-10-06 | P3R01N FF, HPRR01 FF, P3R01G |  | 22d | 135d | TB26 - 2 - Manuf and Delivy | 63,404.5 |  | P3R01S | P3R01S | 860 | R01 | 00 | 2AC2690 | 200 | 200 | 400 | P |  | OWN | 0 | P | R | PR29 | 0000 | AG | LND |
| P3R09BS |  | R09B Air Manifolds - Material arrived at Site | milestone | 0d | 2011-10-13 | 2011-10-13 | HPRR09B FF, P3R09BN FF |  | -34d | 38d | TB26 - 2 - Manuf and Delivy | 44,495 |  | P3R09BS | P3R09BS | 860 | R09B | 00 | 2RE2220 | 200 | 200 | 400 | P |  | OWN | 0 | P | R | PR29 | 0000 | AG | LND |
| P3R07BS |  | R07B Special Pipe Supp. - Material arrived at Site | milestone | 0d | 2011-10-17 | 2011-10-17 | P3R07BN |  | -16d | 91d | TB26 - 2 - Manuf and Delivy | 19,345 |  | P3R07BS1 | P3R07BS | 860 | R07B | 00 | 2RE3370 | 200 | 200 | 400 | P |  | OWN | 0 | P | R | PR29 | 0000 | AG | LND |
| P3A25S |  | A25 Safety Showers - Goods arrived at Site | milestone | 0d | 2012-01-12 | 2012-01-12 | P3A25N FF, P3A25G |  | -90d | 17d | TB26 - 2 - Manuf and Delivy | 13,763 |  | P3A25S | P3A25S | 860 | A25 | 00 | A25 | 200 | 200 | 400 | P |  | OWN | 0 | P | R | PB99 | 0000 | S | LND |

Notes:
- P3N03N: UDF_Actictity Name (Russia): N01 Обшивка металлоконструкций - Прибытие 1-й партии товара на площадку
- P3R06BS1: Expenses: 900A 222021
- P3R06DS1: Expenses: 900A 106928
- P3R02AS1: Expenses: 900A 93298
- P3R06S1: Expenses: 900A 73259.5
- P3R06AS1: Expenses: 900A 30667
- P3R06CS1: Expenses: 900A 155748
- P3R02S1: Expenses: 900A 93298
- P3R07AS1: Expenses: 900A 107843
- P3R04S1: Expenses: 900A 383932
- P3R04AS: Expenses: 900A 20900
- P3R03BS1: Expenses: 900A 16927
- P3R03AS1: Expenses: 900A 37236
- P3R01S: Expenses: 900A 63404.5
- P3R09BS: Expenses: 900A 44495
- P3R07BS: Expenses: 900A 19345
- P3A25S: Expenses: 900A 13763

| ID | WBS | Activity | Type | Duration | Start | Finish | Predecessors | Complete | Total float | Free float | Constraint | Calendar | Cost | Actual cost | UDF_SAVE ACTID | UDF_SAVE ACT ID | Department | Type of Work | Constr. Area | Inquiry/Order No | PMT-Area | PMT-Schedule Org | PMT-Discipline | PMT-Phase | PMT-Respons. | Zeigen/n. Zeigen | WBS Phase | WBS Discipline | WBS Type of Work | WBS Objects | IMS | UPT |
| --- | --- | --- | --- | --- | --- | --- | --- | --- | --- | --- | --- | --- | --- | --- | --- | --- | --- | --- | --- | --- | --- | --- | --- | --- | --- | --- | --- | --- | --- | --- | --- | --- |
|  | E | **E Electrical** |  |  | 2011-04-08 | 2011-11-04 |  |  |  |  |  |  |  |  |  |  |  |  |  |  |  |  |  |  |  |  |  |  |  |  |  |  |
| P3E16S |  | EE16 El.Cable Tray Syst. - 1st Goods arr. at Site | milestone | 0d | 2011-04-08 A | 2011-04-08 A | HPEE16 FF, P3E16D FF+25d | 100% |  |  | finish on 2011-04-08 | TB26 - 2 - Manuf and Delivy |  |  | P3E16S | P3E16S | 87E | E16 | 00 | E16 | 200 | 200 | 400 | P | CC | 0 | P | E | EE29 | 0000 | B | LND |
| P3E03S2 |  | E03 Distrib./Lighting Panel - 1st Goods arrived at Site | milestone | 0d | 2011-07-25 A | 2011-07-25 A | HPEE03, P3E03N FF | 100% |  |  |  | TB26 - 2 - Manuf and Delivy |  |  | P3E03S2 | P3E03S2 | 860 | E03 | 00 | 2EB6150 | 200 | 200 | 400 | P | OWN | 0 | P | E | EE25 | 0000 | IT | LND |
| P3E19S |  | E19 Heat Tracing Syst. - Goods arriv. at Site | milestone | 0d | 2011-07-27 A | 2011-07-27 A | HPEE19 FF, IMS-P-000150 (other project) FF, P3E19G, P3E19N FF | 100% |  |  |  | TB26 - 2 - Manuf and Delivy | 300,000 | 300,000 | P3E19S | P3E19S | 87F | E19 | 00 | 2EB5180 | 200 | 200 | 400 | P | SC | 0 | P | E | EE39 | 0000 | B | LND |
| P3E09S |  | E00 E&I Subcontract - Light./Power Sockets - 1st Goods arr. at Site | milestone | 0d | 2011-07-28 A | 2011-07-28 A | P3E00S SF+45d, HPEE09 FF | 100% |  |  |  | TB26 - 2 - Manuf and Delivy |  |  | P3E09S | P3E09S | 87E | E00 | 00 | 2MD6890 | 200 | 200 | 400 | P | CC | 0 | P | E | EE33 | 0000 | B | LND |
| P3E15BS |  | E15B Elec. LV Power Cable- Goods arrived at Site | milestone | 0d | 2011-09-26 | 2011-09-26 | HPEE15B FF, P3E15BG, IMS-P-000150 (other project) FF, P3E15BN FF |  | 44d | 214d |  | TB26 - 2 - Manuf and Delivy | 50,000 |  | P3E15BS | P3E15BS | 860 | E15B | 00 | 2EB6200 | 200 | 200 | 400 | P | LND | 0 | P | E | EE30 | 0000 | ELE | LND |
| P3E14S |  | E14 Local Switches/PushBS - Goods arrived at Site | milestone | 0d | 2011-10-04 | 2011-10-04 | P3E14N FF, HPEE14 FF, IMS-P-000150 (other project) FF |  | 121d | 206d |  | TB26 - 2 - Manuf and Delivy |  |  | P3E14S | P3E14S | 87E | E14 | 00 | 2EB6120 | 200 | 200 | 400 | P | LND | 0 | P | E | EE36 | 0000 | B | LND |
| P3E15AS |  | E15A Elec. MV Power Cable- Goods arrived at Site | milestone | 0d | 2011-10-26 | 2011-10-26 | P3E15AN FF, P3E15AG, HPEE15A FF |  | -57d | 0d |  | TB26 - 2 - Manuf and Delivy | 85,000 |  | P3E15AS | P3E15AS | 860 | E15A | 00 | 2EB6110 | 200 | 200 | 400 | P | LND | 0 | P | E | EE26 | 0000 | B | LND |
| P3E15CS |  | E15C Cable Glands - Goods arrived at Site | milestone | 0d | 2011-11-04 | 2011-11-04 | HPEE15C FF, P3E15CG, P3E15CN FF |  | 5d | 175d |  | TB26 - 2 - Manuf and Delivy |  |  | P3E15CS | P3E15CS | 860 | E15C | 00 | 2EB6210 | 200 | 200 | 400 | P | LND | 0 | P | E | EE37 | 0000 | ELE | LND |
|  | J | **J Instrumentation** |  |  | 2011-03-31 | 2011-10-18 |  |  |  |  |  |  |  |  |  |  |  |  |  |  |  |  |  |  |  |  |  |  |  |  |  |  |
| P3J04ES |  | J04E Var.Area Flow.(Rotam.) - Goods arr. at Site | milestone | 0d | 2011-03-31 A | 2011-03-31 A | P3J04EG, P3J04EN FF, HPJJ04E FF | 100% |  |  |  | TB26 - 2 - Manuf and Delivy | 33,039 | 33,039 | P3J04ES | P3J04ES | 860 | J04E | 00 | 2JD7330 | 200 | 200 | 400 | P | OWN | 0 | P | J | PJ39 | 0000 | Bulk | LND |
| P3J07BS |  | J07B Switches&Alarms - Goods arrived at Site | milestone | 0d | 2011-03-31 A | 2011-03-31 A | P3J07BN FF, P3J07BG | 100% |  |  |  | TB26 - 2 - Manuf and Delivy |  |  | P3J07BS | P3J07BS | 860 | J07B | 00 | 2JD9490 | 200 | 200 | 400 | P | OWN | 0 | P | J | PJ39 | 0000 | Bulk | LND |
| P3J12BS |  | J12B Magn.Lev.Gauges - Goods arrived at Site | milestone | 0d | 2011-03-31 A | 2011-03-31 A | P3J12BG, P3J12BN FF, HPJJ12B FF | 100% |  |  |  | TB26 - 2 - Manuf and Delivy | 6,608 | 6,608 | P3J12BS | P3J12BS | 860 | J12B | 00 | 2JD8470 | 200 | 200 | 400 | P | OWN | 0 | P | J | PJ39 | 0000 | Bulk | LND |
| P3J02S |  | J02 Control Valves - Goods arrived at Site | milestone | 0d | 2011-04-25 A | 2011-04-25 A | HPJJ02 FF, P3J02N FF, P3J02G | 100% |  |  |  | TB26 - 2 - Manuf and Delivy | 109,375 | 109,375 | P3J02S | P3J02S | 860 | J02 | 00 | 2AJ3030 | 200 | 200 | 400 | P | OWN | 0 | P | J | PJ39 | 0000 | IT | LND |
| P3J01AS |  | J01A Ball Valves - Goods arrived at Site | milestone | 0d | 2011-05-06 A | 2011-05-06 A | HPJJ01A FF, P3J01AG, P3J01AN FF | 100% |  |  |  | TB26 - 2 - Manuf and Delivy | 252,000 | 252,000 | P3J01AS | P3J01AS | 860 | J01A | 00 | 2AJ2610 | 200 | 200 | 400 | P | OWN | 0 | P | J | PJ39 | 0000 | IT | LND |
| P3J01S |  | J01 Ball Valves PDS - Goods arrived at Site | milestone | 0d | 2011-05-06 A | 2011-05-06 A | P3J01G, HPJJ01 FF, P3J01N FF | 100% |  |  |  | TB26 - 2 - Manuf and Delivy | 16,506 | 16,506 | P3J01S | P3J01S | 860 | J01 | 00 | 2AJ2620 | 200 | 200 | 400 | P | OWN | 0 | P | J | PJ39 | 0000 | IT | LND |
| P3J02CS |  | J02C Butterfly V. on/off - Goods arrived at Site | milestone | 0d | 2011-05-06 A | 2011-05-06 A | P3J02CN FF, HPJJ02C FF, P3J02CG | 100% |  |  |  | TB26 - 2 - Manuf and Delivy | 17,878 | 17,878 | P3J02CS | P3J02CS | 860 | J02C | 00 | 2AJ3090 | 200 | 200 | 400 | P | OWN | 0 | P | J | PJ39 | 0000 | IT | LND |
| P3J02AS |  | J02A PCV Valves - Goods arrived at Site | milestone | 0d | 2011-06-10 A | 2011-06-10 A | P3J02AN FF, HPJJ02A FF, P3J02AG | 100% |  |  |  | TB26 - 2 - Manuf and Delivy | 48,662 | 48,662 | P3J02AS | P3J02AS | 860 | J02A | 00 | 2AJ2660 | 200 | 200 | 400 | P | OWN | 0 | P | J | PJ39 | 0000 | IT | LND |
| P3J04AS |  | J04A Coriolis Mass Flowm.- Goods arrived at Site | milestone | 0d | 2011-06-10 A | 2011-06-10 A | HPJJ04A FF, P3J04AN FF, P3J04AG | 100% |  |  |  | TB26 - 2 - Manuf and Delivy | 15,121 | 15,121 | P3J04AS | P3J04AS | 860 | J04A | 00 | 2JD7280 | 200 | 200 | 400 | P | OWN | 0 | P | J | PJ39 | 0000 | Bulk | LND |
| P3J04BS |  | J04B Vortex Flowmeter - Goods arrived at Site | milestone | 0d | 2011-06-10 A | 2011-06-10 A | P3J04BN FF, P3J04BG, HPJJ04B FF | 100% |  |  |  | TB26 - 2 - Manuf and Delivy | 23,127 | 23,127 | P3J04BS | P3J04BS | 860 | J04B | 00 | 2JD9260 | 200 | 200 | 400 | P | LND | 0 | P | J | PJ39 | 0000 | Bulk | LND |
| P3J04CS1 |  | J04C Orifice/Venturi T. - Goods arrived at Site | milestone | 0d | 2011-06-10 A | 2011-06-10 A | P3J04CN FF, P3J04CG | 100% |  |  |  | TB26 - 2 - Manuf and Delivy | 13,216 | 13,216 | P3J04CS1 | P3J04CS1 | 860 | J04C | 00 | 2JD7320 | 200 | 200 | 400 | P | OWN | 0 | P | J | PJ39 | 0000 | Bulk | LND |
| P3J02DS |  | J02D ON/OFF Plug Valves - Goods arrived at Site | milestone | 0d | 2011-06-30 A | 2011-06-30 A | P3J02DN FF, HPJJ02D FF | 100% |  |  |  | TB26 - 2 - Manuf and Delivy | 50,316 | 50,316 | P3J02DS | P3J02DS | 860 | J02D | 00 | 2AJ3020 | 200 | 200 | 400 | P | OWN | 0 | P | J | PJ39 | 0000 | IT | LND |
| P3J07CS |  | J07C Local Indicat. Panels - Goods arrived at Site | milestone | 0d | 2011-07-14 A | 2011-07-14 A | P3J07CG, P3J07CN FF | 100% |  |  |  | TB26 - 2 - Manuf and Delivy |  |  | P3J07CS | P3J07CS | 860 | J07C | 00 | 2JD9500 | 200 | 200 | 400 | P | OWN | 0 | P | J | PJ39 | 0000 | Bulk | LND |
| P3J14S |  | J14 Temp.Transm./Thermoc.- Goods arrived at Site | milestone | 0d | 2011-07-14 A | 2011-07-14 A | P3J14G, P3J14N2, P3J14N, IMS-P-000160 (other project) FF, HPJJ14 FF, P3J14N1 FF | 100% |  |  |  | TB26 - 2 - Manuf and Delivy | 33,039 | 33,039 | P3J14S | P3J14S | 860 | J14 | 00 | 2JD8710 | 200 | 200 | 400 | P | OWN | 0 | P | J | PJ39 | 0000 | Bulk | LND |
| P3J06ES |  | J06E Junction Boxes - 1st Goods arr. at Site | milestone | 0d | 2011-07-22 A | 2011-07-22 A | P3J06EN | 100% |  |  |  | TB26 - 2 - Manuf and Delivy |  |  | P3J06ES | P3J06ES | 860 | J06E | 00 | 2JD9620 | 200 | 200 | 400 | P | LND | 0 | P | J | PJ39 | 0000 | Bulk | LND |
| P3J04IS |  | J04I Ultrasonic Flowm. - Goods arrived at Site | milestone | 0d | 2011-07-23 A | 2011-07-23 A | HPJJ04I FF, P3J04IN FF, P3J04IG | 100% |  |  |  | TB26 - 2 - Manuf and Delivy | 29,735 | 29,735 | P3J04IS | P3J04IS | 860 | J04I | 00 | 2JD8500 | 200 | 200 | 400 | P | OWN | 0 | P | J | PJ39 | 0000 | Bulk | LND |
| P3J05S |  | J05 MPS/CMS - Goods arrived at Site | milestone | 0d | 2011-07-23 A | 2011-07-23 A | P3J05G, P3J05N FF, HPJJ05 FF | 100% |  |  |  | TB26 - 2 - Manuf and Delivy | 130,400 | 130,400 | P3J05S | P3J05S | 860 | J05 | 00 | 2JD7520 | 200 | 200 | 400 | P | OWN | 0 | P | J | PJ29 | 0000 | IT | LND |
| P3J07AS |  | J07A Sample Boards - Goods arrived at Site | milestone | 0d | 2011-08-16 A | 2011-08-16 A | HPJJ07A FF, P3J07AG, P3J07AN FF | 100% |  |  |  | TB26 - 2 - Manuf and Delivy | 8,260 | 8,260 | P3J07AS | P3J07AS | 860 | J07A | 00 | 2JD9480 | 200 | 200 | 400 | P | OWN | 0 | P | J | PJ39 | 0000 | Bulk | LND |
| P3J12AS |  | J12A Radar Level M. - Goods arrived at Site | milestone | 0d | 2011-08-16 A | 2011-08-16 A | P3J12AG, HPJJ12A FF, P3J12AN FF | 100% |  |  |  | TB26 - 2 - Manuf and Delivy | 3,304 | 3,304 | P3J12AS | P3J12AS | 860 | J12A | 00 | 2JD8440 | 200 | 200 | 400 | P | OWN | 0 | P | J | PJ39 | 0000 | Bulk | LND |
| P3J12DS |  | J12D Vibration Fork Level Switch - Goods arrived at Site | milestone | 0d | 2011-08-16 A | 2011-08-16 A | P3J12DG, P3J12DN FF | 100% |  |  |  | TB26 - 2 - Manuf and Delivy | 3,304 | 3,304 | P3J12DS | P3J12DS | 860 | J12D | 00 | 2JD9190 | 200 | 200 | 400 | P | OWN | 0 | P | J | PJ39 | 0000 | Bulk | LND |
| P3J13AS |  | J13A Pressure Gauges - Goods arrived at Site | milestone | 0d | 2011-08-16 A | 2011-08-16 A | P3J13AN FF, HPJJ13A FF, P3J13AG, IMS-P-000160 (other project) FF | 100% |  |  |  | TB26 - 2 - Manuf and Delivy | 6,608 | 6,608 | P3J13AS | P3J13AS | 860 | J13A | 00 | 2JD8480 | 200 | 200 | 400 | P | OWN | 0 | P | J | PJ39 | 0000 | Bulk | LND |
| P3J13BS |  | J13B Pressure Transm. - Goods arrived at Site | milestone | 0d | 2011-08-16 A | 2011-08-16 A | HPJJ13B FF, P3J13BG, P3J13BN FF | 100% |  |  |  | TB26 - 2 - Manuf and Delivy | 33,039 | 33,039 | P3J13BS | P3J13BS | 860 | J13B | 00 | 2JD8690 | 200 | 200 | 400 | P | OWN | 0 | P | J | PJ39 | 0000 | Bulk | LND |
| P3J13S |  | J13 Diff.-/Press.Transm.(F/L) - Goods arrived at Site | milestone | 0d | 2011-08-16 A | 2011-08-16 A | HPJJ13 FF, P3J13N FF, IMS-P-000160 (other project) FF, P3J13G | 100% |  |  |  | TB26 - 2 - Manuf and Delivy | 21,475 | 21,475 | P3J13S | P3J13S | 860 | J13 | 00 | 2JD8840 | 200 | 200 | 400 | P | OWN | 0 | P | J | PJ39 | 0000 | Bulk | LND |
| P3J14AS |  | J14A Thermowell+Elements - Goods arrived at Site | milestone | 0d | 2011-08-16 A | 2011-08-16 A | P3J14AG, IMS-P-000160 (other project) FF, P3J14AN FF, HPJJ14 FF | 100% |  |  |  | TB26 - 2 - Manuf and Delivy | 29,735 | 29,735 | P3J14AS | P3J14AS | 860 | J14A | 00 | 2JD8720 | 200 | 200 | 400 | P | OWN | 0 | P | J | PJ39 | 0000 | INS | LND |
| P3J14BS |  | J14B Temp. Gauges - Goods arrived at Site | milestone | 0d | 2011-08-16 A | 2011-08-16 A | P3J14BG, P3J14BN FF, IMS-P-000160 (other project) FF, HPJJ14B FF | 100% |  |  |  | TB26 - 2 - Manuf and Delivy | 1,652 | 1,652 | P3J14BS | P3J14BS | 860 | J14B | 00 | 2JD8700 | 200 | 200 | 400 | P | OWN | 0 | P | J | PJ39 | 0000 | Bulk | LND |
| P3J17S |  | J17 Instrument Cable - Goods arrived at Site | milestone | 0d | 2011-09-27 | 2011-09-27 | P3J17N |  | 46d | 0d |  | TB26 - 2 - Manuf and Delivy |  |  | P3J17S | P3J17S | 860 | J17 | 00 | 2JD9530 | 200 | 200 | 400 | P | OWN | 0 | P | J | PJ39 | 0000 | Bulk | LND |
| P3J17S1 |  | E00 E&I Subcontract - Instrument Cable - 1st Goods arr. at Site | milestone | 0d | 2011-09-27 | 2011-09-27 | P3J17S, P3E00L SF+100d, HPJJ17 FF |  | 46d | 213.5d |  | TB26 - 2 - Manuf and Delivy |  |  | P3J17S1 | P3J17S1 | 860 | E00 | 00 | 2MD6890 | 200 | 200 | 400 | P | CC | 0 | P | J | PJ59 | 0000 | Bulk | LND |
| P3J06FS |  | J06F PLC Network - Goods arrived at Site | milestone | 0d | 2011-10-13 | 2011-10-13 | P3J06FN FF, P3J06FG, HPJJ06F FF |  | -16d | 0d |  | TB26 - 2 - Manuf and Delivy | 14,400 |  | P3J06FS | P3J06FS | 860 | J06F | 00 | 2JD8450 | 200 | 200 | 400 | P | OWN | 0 | P | J | PJ39 | 0000 | Bulk | LND |
| P3J13CS |  | J13C Pressure Switches - Goods arrived at Site | milestone | 0d | 2011-10-13 | 2011-10-13 | HPJJ13B FF, P3J13CN FF, P3J13CG |  | 95d | 53d |  | TB26 - 2 - Manuf and Delivy | 6,608 |  | P3J13CS | P3J13CS | 860 | J13C | 00 | 2JD8960 | 200 | 200 | 400 | P | OWN | 0 | P | J | PJ39 | 0000 | INS | LND |
| P3J02BS |  | J02B Knife Valves - Goods arrived at Site | milestone | 0d | 2011-10-18 | 2011-10-18 | HPJJ02B FF, P3J02BN FF, P3J02BG |  | -96d | 30d |  | TB26 - 2 - Manuf and Delivy | 13,224 |  | P3J02BS | P3J02BS | 860 | J02B | 00 | 2AJ3000 | 200 | 200 | 400 | P | OWN | 0 | P | J | PJ39 | 0000 | IT | LND |

Notes:
- P3E19S: Expenses: 900A 300000
- P3E15BS: Expenses: 900A 50000
- P3E15AS: Expenses: 900A 85000
- P3J04ES: Expenses: 900A 33039
- P3J12BS: Expenses: 900A 6608
- P3J02S: Expenses: 900A 109375
- P3J01AS: Expenses: 900A 252000
- P3J01S: Expenses: 900A 16506
- P3J02CS: Expenses: 900A 17878
- P3J02AS: Expenses: 900A 48662
- P3J04AS: Expenses: 900A 15121
- P3J04BS: Expenses: 900A 23127
- P3J04CS1: Expenses: 900A 13216
- P3J02DS: Expenses: 900A 50316
- P3J14S: Expenses: 900A 33039
- P3J06ES: Current Status: O.Siegel: Info von Frau Baumgartner, / dass die JB nicht vor KW29 (in CBA) geliefert werden. danach werden noch 14 Tage / fьr die Entzollung und Transport zur Baustelle benцtigt.
- P3J04IS: Expenses: 900A 29735
- P3J05S: Expenses: 900A 130400
- P3J07AS: Expenses: 900A 8260
- P3J12AS: Expenses: 900A 3304
- P3J12DS: Expenses: 900A 3304
- P3J13AS: Expenses: 900A 6608
- P3J13BS: Expenses: 900A 33039
- P3J13S: Expenses: 900A 21475
- P3J14AS: Expenses: 900A 29735
- P3J14BS: Expenses: 900A 1652
- P3J06FS: Expenses: 900A 14400
- P3J13CS: Expenses: 900A 6608
- P3J02BS: Expenses: 900A 13224

| ID | WBS | Activity | Type | Duration | Start | Finish | Predecessors | Complete | Total float | Free float | Calendar | Cost | Actual cost | UDF_SAVE ACTID | UDF_SAVE ACT ID | Department | Type of Work | Constr. Area | Inquiry/Order No | PMT-Area | PMT-Schedule Org | PMT-Discipline | PMT-Phase | PMT-Respons. | Zeigen/n. Zeigen | WBS Phase | WBS Discipline | WBS Type of Work | WBS Objects | IMS | UPT | Pro Unit/DocCode | PMT-Stage | PMT-Doc. Type |
| --- | --- | --- | --- | --- | --- | --- | --- | --- | --- | --- | --- | --- | --- | --- | --- | --- | --- | --- | --- | --- | --- | --- | --- | --- | --- | --- | --- | --- | --- | --- | --- | --- | --- | --- |
|  | S | **S Safety & Environment** |  |  | 2011-03-26 | 2011-10-21 |  |  |  |  |  |  |  |  |  |  |  |  |  |  |  |  |  |  |  |  |  |  |  |  |  |  |  |  |
| P3S08BS |  | S08B Monitors - Goods arrived at Site | milestone | 0d | 2011-03-26 A | 2011-03-26 A | P3S08BN FF | 100% |  |  | TB26 - 2 - Manuf and Delivy | 19,300 | 19,300 | P3S08BS | P3S08BS | 860 | S08B | 00 | 2SI1930 | 200 | 200 | 400 | P | OWN | 0 | P | S | PS29 | 0000 | P | LND |  |  |  |
| P3S08S |  | S08A Hydrants - Goods arrived at Site | milestone | 0d | 2011-03-26 A | 2011-03-26 A | P3S08N FF, HPSS08 FF | 100% |  |  | TB26 - 2 - Manuf and Delivy | 19,300 | 19,300 | P3S08S | P3S08S | 860 | S08A | 00 | 2SI1810 | 200 | 200 | 400 | P | OWN | 0 | P | S | PS29 | 0000 | AG | LND |  |  |  |
| P3S06S |  | S06 Sprinkler System - Goods arrived at Site | milestone | 0d | 2011-08-12 A | 2011-08-12 A | P3S06G, HPSS06 FF, P3S06N FF | 100% |  |  | TB26 - 2 - Manuf and Delivy | 51,500 | 51,500 | P3S06S | P3S06S | 860 | S06 | 00 | 2SI1740 | 200 | 200 | 400 | P | OWN | 0 | P | S | PS29 | 0000 | AG | LND |  |  |  |
| P3S07S |  | S07 Deluge System - Goods arrived at Site | milestone | 0d | 2011-08-12 A | 2011-08-12 A | P3S07G, HPSS07 FF, P3S07N FF | 100% |  |  | TB26 - 2 - Manuf and Delivy | 51,500 | 51,500 | P3S07S | P3S07S | 860 | S07 | 00 | 2SI1730 | 200 | 200 | 400 | P | OWN | 0 | P | S | PS29 | 0000 | UG | LND |  |  |  |
| P3S01S |  | S01 Safety Relief Valves - Goods arrived at Site | milestone | 0d | 2011-08-16 A | 2011-08-16 A | P3S01N FF, HPSS01 FF, P3S01G | 100% |  |  | TB26 - 2 - Manuf and Delivy | 65,100 | 65,100 | P3S01S | P3S01S | 860 | S01 | 00 | 2SI1760 | 200 | 200 | 400 | P | OWN | 0 | P | S | PS29 | 0000 | IT | LND |  |  |  |
| P3S09S |  | S09 Minor FF Equipment - Goods arrived at Site | milestone | 0d | 2011-10-14 | 2011-10-14 | P3S09G, HPSS09 FF, P3S09N FF |  | 58.88d | 111d | TB26 - 2 - Manuf and Delivy | 11,500 |  | P3S09S | P3S09S | 860 | S09 | 00 | 2SI1890 | 200 | 200 | 400 | P | OWN | 0 | P | S | PS29 | 0000 | AG | LND |  |  |  |
| P3S02S |  | S02 Rupture Disks - Goods arrived at Site | milestone | 0d | 2011-10-18 | 2011-10-18 | P3S02G, P3S02N FF, HPSS02 FF |  | -7d | 53d | TB26 - 2 - Manuf and Delivy | 7,000 |  | P3S02S | P3S02S | 860 | S02 | 00 | 2SI1750 | 200 | 200 | 400 | P | OWN | 0 | P | S | PS29 | 0000 | AG | LND |  |  |  |
| P3S10S |  | S10 Flame Arrestors - Goods arrived at Site | milestone | 0d | 2011-10-18 | 2011-10-18 | P3S10G, P3S10N FF |  | -63d | 8d | TB26 - 2 - Manuf and Delivy |  |  | P3S10S | P3S10S | 860 | S10 | 00 | 2SI1880 | 200 | 200 | 400 | P | OWN | 0 | P | S | PS29 | 0000 | P | LND |  |  |  |
| P3S05S |  | S05 Gas Exting. Syst. - Goods arrived at Site | milestone | 0d | 2011-10-21 | 2011-10-21 | P3S05N FF, HPSS05 FF, P3S05G |  | -1d | 64d | TB26 - 2 - Manuf and Delivy | 49,000 |  | P3S05S | P3S05S | 860 | S05 | 00 | 2SI1770 | 200 | 200 | 400 | P | OWN | 0 | P | S | PS29 | 0000 | AG | LND |  |  |  |
|  | 1110 | **1110 Offgas Compressor Building - CA11** |  |  | 2007-12-20 | 2011-01-10 |  |  |  |  |  |  |  |  |  |  |  |  |  |  |  |  |  |  |  |  |  |  |  |  |  |  |  |  |
|  | M | **M Mechanical - Rotating Equipment** |  |  | 2007-12-20 | 2011-01-10 |  |  |  |  |  |  |  |  |  |  |  |  |  |  |  |  |  |  |  |  |  |  |  |  |  |  |  |  |
| P3M03A |  | M03 Offgas Compr. - Prepare Spec./Issue RFQ |  | 8d | 2007-12-20 A | 2008-01-07 A | F1540 SS, F1660 SS | 100% |  |  |  |  |  | P3M03A | P3M03A | 860 | M03 | 00 | 2DC8460 | 200 | 200 | 400 | P | LND | C2 | P | M | PM11 | 1110 | E | LND | DC | 3A | DEV |
| F6360 |  | M03 Offgas Compr. - Vendor Bid Preparation |  | 32d | 2008-01-08 A | 2008-02-20 A | P3M03B | 100% |  |  |  |  |  | F6360 | F6360 | 860 | M03 | 00 | 2DC8460 | 200 | 200 | 400 | P | LND | C2 | P | M | PM11 | 1110 | 1 | LND | DC | 3A |  |
| F6460 |  | M03 Offgas Compr. - PMT approve RFQ |  | 23d | 2008-01-08 A | 2008-02-07 A | F6480 | 100% |  |  |  |  |  | F6460 | F6460 | 860 | M03 | 00 | 2DC8460 | 200 | 200 | 400 | P | PMT | C2 | P | M | PM11 | 1110 | 1 | LND |  | 3A |  |
| F6480 |  | M03 Offgas Compr. - Issue RFQ to PMT | milestone | 0d | 2008-01-08 A | 2008-01-08 A | P3M03B FF | 100% |  |  |  |  |  | F6480 | F6480 | 860 | M03 | 00 | 2DC8460 | 200 | 200 | 400 | P | LND | C2 | P | M | PM11 | 1110 | 1 | LND |  | 3A |  |
| P3M03B |  | M03 Offgas Compr. - RFQ issued to bidders | milestone | 0d | 2008-01-08 A | 2008-01-08 A | P3M03A FF | 100% |  |  |  | 221,776 | 221,776 | P3M03B | P3M03B | 860 | M03 | 00 | 2DC8460 | 200 | 200 | 400 | P | LND | C2 | P | M | PM11 | 1110 | E | LND | DC | 3A |  |
| F6490 |  | M03 Offgas Compr. - Vendor Bid for INEOS Review | milestone | 0d | 2008-02-21 A | 2008-02-21 A | F6360, F6460 | 100% |  |  |  |  |  | F6490 | F6490 | 860 | M03 | 00 | 2DC8460 | 200 | 200 | 400 | P | LND | C2 | P | M | PM12 | 1110 | 1 | LND |  | 3A |  |
| P3M03C |  | M03 Offgas Compr. - Eval./Negotiation |  | 47d | 2008-03-14 A | 2008-05-23 A | F6410 | 100% |  |  |  |  |  | P3M03C | P3M03C | 860 | M03 | 00 | 2DC8460 | 200 | 200 | 400 | P | LND | C2 | P | M | PM12 | 1110 | E | LND | DC | 3A |  |
| F6540 |  | M03 Offgas Compr. - Bid tab Client appr. |  | 7d | 2008-05-13 A | 2008-05-21 A | E3M0330, P3M03C FF | 100% |  |  |  |  |  | F6540 | F6540 | 860 | M03 | 00 | 2DC8460 | 200 | 200 | 400 | P | PMT | C2 | P | M | PM12 | 1110 | 1 | LND |  | 3A |  |
| P3M03D |  | M03 Offgas Compr. - PO issued | milestone | 0d | 2008-05-24 A | 2008-05-24 A | F6540 FF, F2930 FF, E3M0320, P3M03C FF | 100% |  |  |  | 887,104 | 887,104 | P3M03D | P3M03D | 860 | M03 | 00 | 2DC8460 | 200 | 200 | 400 | P | LND | C2 | P | M | PM13 | 1110 | E | LND | DC | 3A |  |
| P3M03L |  | M03 Offgas Compr. - Lead Time/Fabrication |  | 874d | 2008-05-24 A | 2010-10-22 A | E3M0380 FF+140d, P3M03D | 100% |  |  | TB26 - 2 - Manuf and Delivy |  |  | P3M03L | P3M03L | 860 | M03 | 00 | 2DC8460 | 200 | 200 | 400 | P | LND | C2 | P | M | PM16 | 1110 | E | LND | DC |  | DEL |
| P3M03X |  | M03 Offgas Compr. - Final Inspection | milestone | 0d | 2010-10-01 A | 2010-10-01 A | P3M03L FF-5d, E3M0360 FF+10d, E3M0380 | 100% |  |  | TB26 - 2 - Manuf and Delivy | 1,330,656 | 1,330,656 | P3M03X | P3M03X | 860 | M03 | 00 | 2DC8460 | 200 | 200 | 400 | P | LND | C2 | P | M | PM17 | 1110 | E | LND | DC |  |  |
| P3M03M |  | M03 Offgas Compr. - Goods delivered FOB | milestone | 0d | 2010-10-29 A | 2010-10-29 A | P3M03L FF+10d | 100% |  |  | TB26 - 2 - Manuf and Delivy | 665,328 | 665,328 | P3M03M | P3M03M | 860 | M03 | 00 | 2DC8460 | 200 | 200 | 400 | P | LND | C2 | P | M | PM18 | 1110 | E | LND | DC |  |  |
| P3M03N |  | M03 Offgas Compr. - Transport to Site |  | 38d | 2010-12-01 A | 2011-01-10 A | P3M03X, P3M03M, P3M03L, P3B100 FF | 100% |  |  | TB26 - 2 - Manuf and Delivy |  |  | P3M03N | P3M03N | 860 | M03 | 00 | 2DC8460 | 200 | 200 | 400 | P | LND | C2 | P | M | PM18 | 1110 | E | LND | DC |  |  |

Notes:
- P3S08BS: Expenses: 900A 19300
- P3S08S: Expenses: 900A 19300
- P3S06S: Expenses: 900A 51500
- P3S07S: Expenses: 900A 51500
- P3S01S: Expenses: 900A 65100
- P3S09S: Expenses: 900A 11500
- P3S02S: Expenses: 900A 7000
- P3S05S: Expenses: 900A 49000
- P3M03B: Expenses: 900A 221776
- P3M03D: Expenses: 900A 887104
- P3M03L: P3 Activity Log Info: 17 / month
- P3M03X: Expenses: 900A 1330656
- P3M03M: Expenses: 900A 665328
- P3M03N: P3 Activity Log Info: Train (20days), custom / clearance (30days)

| ID | WBS | Activity | Type | Duration | Start | Finish | Predecessors | Complete | Calendar | Cost | Actual cost | UDF_SAVE ACTID | UDF_SAVE ACT ID | Department | Type of Work | Constr. Area | Pro Unit/DocCode | Inquiry/Order No | PMT-Area | PMT-Schedule Org | PMT-Discipline | PMT-Phase | PMT-Stage | PMT-Doc. Type | PMT-Respons. | Zeigen/n. Zeigen | WBS Phase | WBS Discipline | WBS Type of Work | WBS Objects | IMS | UPT | UDF_Actictity Name (Russia) |
| --- | --- | --- | --- | --- | --- | --- | --- | --- | --- | --- | --- | --- | --- | --- | --- | --- | --- | --- | --- | --- | --- | --- | --- | --- | --- | --- | --- | --- | --- | --- | --- | --- | --- |
|  | 1201 | **1201 Reactor Structure - CA12** |  |  | 2007-12-10 | 2010-08-28 |  |  |  |  |  |  |  |  |  |  |  |  |  |  |  |  |  |  |  |  |  |  |  |  |  |  |  |
|  | B | **B Mechanical - Stationary Equipment** |  |  | 2007-12-10 | 2010-08-28 |  |  |  |  |  |  |  |  |  |  |  |  |  |  |  |  |  |  |  |  |  |  |  |  |  |  |  |
| P3ALL1A |  | ALL1 React. w Agitators - PrepareSpec./Issue RFQ |  | 9d | 2007-12-10 A | 2007-12-20 A | F1660 SS-5d, F1540 SS | 100% |  |  |  | P3ALL1A | P3ALL1A | 860 | ALL1 | 00 | DC | 2DC8440 | 200 | 200 | 400 | P | 3A | DEV | LND | C2 | P | B | PB31 | 1201 | E | LND |  |
| F4860 |  | ALL1 React. w Agitators - Vendor Bid Preparation |  | 16d | 2007-12-21 A | 2008-01-18 A | P3ALL1B | 100% |  |  |  | F4860 | F4860 | 860 | ALL1 | 00 | DC | 2DC8440 | 200 | 200 | 400 | P | 3A |  | LND | C2 | P | B | PB31 | 1201 | C | LND |  |
| P3ALL1B |  | ALL1 React. w Agitators - RFQ issued to bidders | milestone | 0d | 2007-12-21 A | 2007-12-21 A | P3ALL1A FF | 100% |  | 257,425 | 257,425 | P3ALL1B | P3ALL1B | 860 | ALL1 | 00 | DC | 2DC8440 | 200 | 200 | 400 | P | 3A |  | LND | C2 | P | B | PB31 | 1201 | E | LND |  |
| F4980 |  | ALL1 React. w Agitators - PMT approve RFQ |  | 15d | 2008-01-07 A | 2008-01-25 A | F4970 | 100% |  |  |  | F4980 | F4980 | 860 | ALL1 | 00 |  | 2DC8440 | 200 | 200 | 400 | P | 3A |  | PMT | C2 | P | B | PB31 | 1201 | C | LND |  |
| F4970 |  | ALL1 React. w Agitators - Issue RFQ to PMT | milestone | 0d | 2008-01-08 A | 2008-01-08 A | P3ALL1B FF | 100% |  |  |  | F4970 | F4970 | 860 | ALL1 | 00 |  | 2DC8440 | 200 | 200 | 400 | P | 3A |  | LND | C2 | P | B | PB31 | 1201 | C | LND |  |
| F4910 |  | ALL1 React. w Agitators - Evaluate Bids |  | 5d | 2008-01-18 A | 2008-01-24 A | F4860 | 100% |  |  |  | F4910 | F4910 | 860 | ALL1 | 00 | DC | 2DC8440 | 200 | 200 | 400 | P | 3A |  | LND | C2 | P | B | PB32 | 1201 | C | LND |  |
| F5040 |  | ALL1 React. w Agitators - Bid tab Client appr. |  | 11d | 2008-01-25 A | 2008-02-08 A | E3ALL130, E3ALL120 | 100% |  |  |  | F5040 | F5040 | 860 | ALL1 | 00 |  | 2DC8440 | 200 | 200 | 400 | P | 3A |  | PMT | C2 | P | B | PB32 | 1201 | 1 | LND |  |
| P3ALL1C |  | ALL1 React. w Agitators - Eval./Negotiation |  | 11d | 2008-01-25 A | 2008-02-08 A | F4910 | 100% |  |  |  | P3ALL1C | P3ALL1C | 860 | ALL1 | 00 | DC | 2DC8440 | 200 | 200 | 400 | P | 3A |  | LND | C2 | P | B | PB32 | 1201 | E | LND |  |
| F4990 |  | ALL1 React. w Agit.- Vendor Bid for INEOS Review |  | 3d | 2008-02-08 A | 2008-02-12 A | F4860, F4980 | 100% |  |  |  | F4990 | F4990 | 860 | ALL1 | 00 |  | 2DC8440 | 200 | 200 | 400 | P | 3A |  | LND | C2 | P | B | PB32 | 1201 | C | LND |  |
| P3ALL1D |  | ALL1 React. w Agitators - PO issued | milestone | 0d | 2008-02-13 A | 2008-02-13 A | E3ALL120 FS-1d, F2930 FF, F5040 FF+2d, F4990 | 100% |  | 1,029,700 | 1,029,700 | P3ALL1D | P3ALL1D | 860 | ALL1 | 00 | DC | 2DC8440 | 200 | 200 | 400 | P | 3A |  | LND | C2 | P | B | PB33 | 1201 | E | LND |  |
| P3ALL1L |  | ALL1 React. w Agitators - Lead Time/Fabrication |  | 848d | 2008-02-13 A | 2010-06-18 A | F3410, P3ALL1D | 100% | TB26 - 2 - Manuf and Delivy |  |  | P3ALL1L | P3ALL1L | 860 | ALL1 | 00 | DC | 2DC8440 | 200 | 200 | 400 | P |  | DEL | LND | C2 | P | B | PB36 | 1201 | E | LND |  |
| P3ALL1X |  | ALL1 React. w Agitators - Final Inspection |  | 5d | 2010-05-17 A | 2010-05-21 A | E3ALL160 FF+10d, P3ALL1L FF-16d | 100% | TB26 - 2 - Manuf and Delivy | 1,544,550 | 1,544,550 | P3ALL1X | P3ALL1X | 860 | ALL1 | 00 | DC | 2DC8440 | 200 | 200 | 400 | P |  |  | LND | C2 | P | B | PB37 | 1201 | E | LND |  |
| P3ALL1G |  | ALL1 Gost R Certificate to russ. customs | milestone | 0d | 2010-05-18 A | 2010-05-18 A | P3ALL1N FF-90d | 100% | TB26 - 2 - Manuf and Delivy |  |  | P3ALL1G | P3ALL1G | 860 | ALL1 | 00 |  | 2DC8440 | 200 | 200 | 400 | P |  |  | LND | 0 | P | B | PB38 | 1201 | E | LND |  |
| P3ALL1M |  | ALL1 React. w Agitators - Goods delivered FOB/EXW | milestone | 0d | 2010-06-30 A | 2010-06-30 A | P3ALL1L FF+9d | 100% | TB26 - 2 - Manuf and Delivy | 772,275 | 772,275 | P3ALL1M | P3ALL1M | 860 | ALL1 | 00 | DC | 2DC8440 | 200 | 200 | 400 | P |  |  | LND | C2 | P | B | PB38 | 1201 | E | LND |  |
| P3ALL1N |  | ALL1 React. w Agitators - Transport to Site |  | 40d | 2010-07-20 A | 2010-08-28 A | P3ALL1L, P3ALL1N1 SS, P3ALL1M, P3ALL1X | 100% | TB26 - 2 - Manuf and Delivy |  |  | P3ALL1N | P3ALL1N | 860 | ALL1 | 00 | DC | 2DC8440 | 200 | 200 | 400 | P |  |  | LND | C2 | P | B | PB38 | 1201 | E | LND |  |
| P3ALL1N1 |  | ALL1 React. w Agitators - Ship N.Sea-Archangelsk |  | 15d | 2010-07-20 A | 2010-08-03 A | P3ALL1M | 100% | TB26 - 2 - Manuf and Delivy |  |  | P3ALL1N1 | P3ALL1N1 | 860 | ALL1 | 00 | DC | 2DC8440 | 200 | 200 | 400 | P |  |  | LND | C2 | P | B | PB38 | 1201 | E | LND |  |
| P3ALL1N3 |  | ALL1 React. w Agitators-Ship Archangelsk-Tobolsk |  | 15d | 2010-08-04 A | 2010-08-18 A | P3ALL1N1 | 100% | TB26 - 2 - Manuf and Delivy |  |  | P3ALL1N3 | P3ALL1N3 | 860 | ALL1 | 00 | DC | 2DC8440 | 200 | 200 | 400 | P |  |  | LND | C2 | P | B | PB38 | 1201 | E | LND |  |
| P3ALL1N5 |  | ALL1 React. w Agitators -Custom clearance Period |  | 10d | 2010-08-19 A | 2010-08-28 A | P3ALL1N3 | 100% | TB26 - 2 - Manuf and Delivy |  |  | P3ALL1N5 | P3ALL1N5 | 860 | ALL1 | 00 | DC | 2DC8440 | 200 | 200 | 400 | P |  |  | LND | C2 | P | B | PB38 | 1201 | E | LND |  |
|  | LUZ1 | **LUZ1 Lutz Kern - Procurement** |  |  | 2008-09-15 | 2011-12-09 |  |  |  |  |  |  |  |  |  |  |  |  |  |  |  |  |  |  |  |  |  |  |  |  |  |  |  |
|  | R | **R Piping** |  |  | 2008-09-15 | 2011-12-09 |  |  |  |  |  |  |  |  |  |  |  |  |  |  |  |  |  |  |  |  |  |  |  |  |  |  |  |
| F3120 |  | Piping Procurement & Supply | level of effort | 635d | 2008-09-15 A | 2011-03-25 A | P3R02A SS, P3R06CA SS, P3R01A SS, P3R06A SS, P3R06AA SS, P3R06BA SS, P3R02BA SS, P3R06DA SS, P3R02AA SS | 100% |  |  |  | F3120 | F3120 | 860 |  | 00 | 91 |  | 200 |  |  | P |  |  |  |  | P | R | PR20 | LUZ1 | PI | LND |  |
| P3R04A |  | R04 AG Gate Valves - Prepare/Issue RFQ |  | 5d | 2008-09-15 A | 2008-09-19 A | E3R0410 | 100% |  |  |  | P3R04A | P3R04A | 860 | R04 | 00 |  | 2AC2600 | 200 | 200 | 400 | P |  | DEV | LND | 0 | P | R | PR21 | LUZ1 | PI | LND |  |
| P3R06A |  | R06 AG Fittings CS - Prepare/Issue RFQ |  | 5d | 2008-09-15 A | 2008-09-19 A | E3R0610 | 100% |  |  |  | P3R06A | P3R06A | 860 | R06 | 00 |  | 2RE1820 | 200 | 200 | 400 | P |  | DEV | LND | 0 | P | R | PR21 | LUZ1 | PI | LND |  |
| P3R06AA |  | R06A AG Fittings SS - Prepare/Issue RFQ |  | 5d | 2008-09-15 A | 2008-09-19 A | E3R06A10 | 100% |  |  |  | P3R06AA | P3R06AA | 860 | R06A | 00 |  | 2RE1830 | 200 | 200 | 400 | P |  | DEV | LND | 0 | P | R | PR21 | LUZ1 | PI | LND |  |
| P3R06BA |  | R06B AG Pipes CS - Prepare/Issue RFQ |  | 4d | 2008-09-17 A | 2008-09-22 A | E3R06B10 | 100% |  |  |  | P3R06BA | P3R06BA | 860 | R06B | 00 |  | 2RE1800 | 200 | 200 | 400 | P |  | DEV | LND | 0 | P | R | PR21 | LUZ1 | PI | LND |  |
| P3R06CA |  | R06C AG Pipes SS - Prepare/Issue RFQ |  | 4d | 2008-09-17 A | 2008-09-22 A | E3R06C10 | 100% |  |  |  | P3R06CA | P3R06CA | 860 | R06C | 00 |  | 2RE1810 | 200 | 200 | 400 | P |  | DEV | LND | 0 | P | R | PR21 | LUZ1 | PI | LND |  |
| P3R06DA |  | R06D AG Flanges CS/SS - Prepare/Issue RFQ |  | 4d | 2008-09-17 A | 2008-09-22 A | E3R06D10 | 100% |  |  |  | P3R06DA | P3R06DA | 860 | R06D | 00 |  | 2RE1840 | 200 | 200 | 400 | P |  | DEV | LND | 0 | P | R | PR21 | LUZ1 | PI | LND |  |
| P3R04B |  | R04 AG Gate Valves - RFQ issued | milestone | 0d | 2008-09-20 A | 2008-09-20 A | P3R04A FF | 100% |  | 191,966.25 | 191,966.25 | P3R04B | P3R04B | 860 | R04 | 00 |  | 2AC2600 | 200 | 200 | 400 | P |  | DEV | LND | 0 | P | R | PR21 | LUZ1 | PI | LND |  |
| P3R06AB |  | R06A AG Fittings SS - RFQ issued | milestone | 0d | 2008-09-20 A | 2008-09-20 A | P3R06AA FF | 100% |  | 15,333.5 | 15,333.5 | P3R06AB | P3R06AB | 860 | R06A | 00 |  | 2RE1830 | 200 | 200 | 400 | P |  | DEV | LND | 0 | P | R | PR21 | LUZ1 | PI | LND |  |
| P3R06B |  | R06 AG Fittings CS - RFQ issued | milestone | 0d | 2008-09-20 A | 2008-09-20 A | P3R06A FF | 100% |  | 36,629.75 | 36,629.75 | P3R06B | P3R06B | 860 | R06 | 00 |  | 2RE1820 | 200 | 200 | 400 | P |  | DEV | LND | 0 | P | R | PR21 | LUZ1 | PI | LND |  |
| P3R06BB |  | R06B AG Pipes CS - RFQ issued | milestone | 0d | 2008-09-23 A | 2008-09-23 A | P3R06BA FF | 100% |  | 111,010.5 | 111,010.5 | P3R06BB | P3R06BB | 860 | R06B | 00 |  | 2RE1800 | 200 | 200 | 400 | P |  | DEV | LND | 0 | P | R | PR21 | LUZ1 | PI | LND |  |
| P3R06CB |  | R06C AG Pipes SS - RFQ issued | milestone | 0d | 2008-09-23 A | 2008-09-23 A | P3R06CA FF | 100% |  | 77,874 | 77,874 | P3R06CB | P3R06CB | 860 | R06C | 00 |  | 2RE1810 | 200 | 200 | 400 | P |  | DEV | LND | 0 | P | R | PR21 | LUZ1 | PI | LND |  |
| P3R06DB |  | R06D AG Flanges CS/SS - RFQ issued | milestone | 0d | 2008-09-23 A | 2008-09-23 A | P3R06DA FF | 100% |  | 53,464.25 | 53,464.25 | P3R06DB | P3R06DB | 860 | R06D | 00 |  | 2RE1840 | 200 | 200 | 400 | P |  | DEV | LND | 0 | P | R | PR21 | LUZ1 | PI | LND |  |
| F4680 |  | Inquiry AG-Piping Material PID Download D2 |  | 55d | 2008-11-03 A | 2009-01-26 A | F2760 | 100% |  |  |  | F4680 | F4680 | 860 |  | 00 |  |  | 200 |  |  | P |  |  |  |  | P | R | PR21 | LUZ1 |  | LND |  |
| F4620 |  | AG-Piping Material 1st MTO |  | 15d | 2008-12-01 A | 2008-12-19 A | AD2060, F4680, A1KR0020 FF | 100% |  |  |  | F4620 | F4620 | 860 |  | 00 | 91 |  | 200 |  |  | P |  |  |  | L2 | P | R | PR23 | LUZ1 |  | LND | 1-е MTO на материалы надземных трубопроводов |
| F4650 |  | AG-Piping Material 2nd MTO |  | 25d | 2009-01-12 A | 2009-02-13 A | A1KR1315 FF, A1KL1133 | 100% |  |  |  | F4650 | F4650 | 860 |  | 00 | 91 |  | 200 |  |  | P |  |  |  | L2 | P | R | PR23 | LUZ1 |  | LND | 2-е MTO на материалы надземных трубопроводов |
| P3R02A |  | R02 UG GFK Pipes - Prepare/Issue RFQ |  | 5d | 2009-01-26 A | 2009-01-30 A | E3R0210 | 100% |  |  |  | P3R02A | P3R02A | 860 | R02 | 00 |  | 2RE1350 | 200 | 200 | 400 | P |  | DEV | LND | 0 | P | R | PR21 | LUZ1 | PI | LND |  |
| P3R02B |  | R02 UG GFK Pipes - RFQ issued | milestone | 0d | 2009-01-31 A | 2009-01-31 A | P3R02A FF | 100% |  | 46,649 | 46,649 | P3R02B | P3R02B | 860 | R02 | 00 |  | 2RE1350 | 200 | 200 | 400 | P |  | DEV | LND | 0 | P | R | PR21 | LUZ1 | PI | LND |  |
| P3R02AA |  | R02A UG Cast Iron Pipes - Prepare/Issue RFQ |  | 3d | 2009-02-03 A | 2009-02-05 A | E3R02A10 | 100% |  |  |  | P3R02AA | P3R02AA | 860 | R02A | 00 |  | 2RE2240 | 200 | 200 | 400 | P |  | DEV | LND | 0 | P | R | PR21 | LUZ1 | PI | LND |  |
| P3R02BA |  | R02B HDPE Pipes - Prepare/Issue RFQ |  | 3d | 2009-02-03 A | 2009-02-05 A | E3R02B10 | 100% |  |  |  | P3R02BA | P3R02BA | 860 | R02B | 00 |  | 2RE2290 | 200 | 200 | 400 | P |  | DEV | LND | 0 | P | R | PR21 | LUZ1 | PI | LND |  |
| P3R02AB |  | R02A UG Cast Iron Pipes - RFQ issued | milestone | 0d | 2009-02-06 A | 2009-02-06 A | P3R02AA FF | 100% |  | 46,649 | 46,649 | P3R02AB | P3R02AB | 860 | R02A | 00 |  | 2RE2240 | 200 | 200 | 400 | P |  | DEV | LND | 0 | P | R | PR21 | LUZ1 | PI | LND |  |
| P3R02BB |  | R02B HDPE Pipes - RFQ issued | milestone | 0d | 2009-02-06 A | 2009-02-06 A | P3R02BA FF | 100% |  |  |  | P3R02BB | P3R02BB | 860 | R02B | 00 |  | 2RE2290 | 200 | 200 | 400 | P |  | DEV | LND | 0 | P | R | PR21 | LUZ1 | PI | LND |  |
| P3R02AC |  | R02A UG Cast Iron Pipes - Eval./Negotiation |  | 294d | 2009-04-09 A | 2010-06-14 A | E3R02A20 FF, P3R02AB | 100% |  |  |  | P3R02AC | P3R02AC | 860 | R02A | 00 |  | 2RE2240 | 200 | 200 | 400 | P |  |  | LND | 0 | P | R | PR22 | LUZ1 | PI | LND |  |
| P3R02BC |  | R02B HDPE Pipes - Eval./Negotiation |  | 468d | 2009-04-09 A | 2011-02-16 A | P3R02BB, E3R02B20 FF | 100% |  |  |  | P3R02BC | P3R02BC | 860 | R02B | 00 |  | 2RE2290 | 200 | 200 | 400 | P |  |  | LND | 0 | P | R | PR22 | LUZ1 | PI | LND |  |
| P3R02C |  | R02 UG GFK Pipes - Eval./Negotiation |  | 280d | 2009-04-23 A | 2010-06-04 A | P3R02B, E3R0220 FF | 100% |  |  |  | P3R02C | P3R02C | 860 | R02 | 00 |  | 2RE1350 | 200 | 200 | 400 | P |  |  | LND | 0 | P | R | PR22 | LUZ1 | PI | LND |  |
| P3R06AC |  | R06A AG Fittings SS - Eval./Negotiation |  | 136d | 2009-09-17 A | 2010-04-01 A | P3R06AB, E3R06A20 FF | 100% |  |  |  | P3R06AC | P3R06AC | 860 | R06A | 00 |  | 2RE1830 | 200 | 200 | 400 | P |  |  | LND | 0 | P | R | PR22 | LUZ1 | PI | LND |  |
| P3R06BC |  | R06B AG Pipes CS - Eval./Negotiation |  | 108d | 2009-09-17 A | 2010-02-22 A | P3R06BB, E3R06B20 FF | 100% |  |  |  | P3R06BC | P3R06BC | 860 | R06B | 00 |  | 2RE1800 | 200 | 200 | 400 | P |  |  | LND | 0 | P | R | PR22 | LUZ1 | PI | LND |  |
| P3R06C |  | R06 AG Fittings CS - Eval./Negotiation |  | 111d | 2009-09-17 A | 2010-02-25 A | E3R0620 FF, P3R06B | 100% |  |  |  | P3R06C | P3R06C | 860 | R06 | 00 |  | 2RE1820 | 200 | 200 | 400 | P |  |  | LND | 0 | P | R | PR22 | LUZ1 | PI | LND |  |
| P3R06CC |  | R06C AG Pipes SS - Eval./Negotiation |  | 137d | 2009-09-17 A | 2010-04-06 A | P3R06CB, E3R06C20 FF | 100% |  |  |  | P3R06CC | P3R06CC | 860 | R06C | 00 |  | 2RE1810 | 200 | 200 | 400 | P |  |  | LND | 0 | P | R | PR22 | LUZ1 | PI | LND |  |
| P3R06DC |  | R06D AG Flanges CS/SS - Eval./Negotiation |  | 111d | 2009-09-17 A | 2010-02-25 A | P3R06DB, E3R06D20 FF | 100% |  |  |  | P3R06DC | P3R06DC | 860 | R06D | 00 |  | 2RE1840 | 200 | 200 | 400 | P |  |  | LND | 0 | P | R | PR22 | LUZ1 | PI | LND |  |
| P3R04C |  | R04 AG Gate Valves - Eval./Negotiation |  | 107d | 2009-10-05 A | 2010-03-09 A | P3R04B, E3R0420 FF | 100% |  |  |  | P3R04C | P3R04C | 860 | R04 | 00 |  | 2AC2600 | 200 | 200 | 400 | P |  |  | LND | 0 | P | R | PR22 | LUZ1 | PI | LND |  |
| P3R06BD |  | R06B AG Pipes CS - 1st PO issued | milestone | 0d | 2010-02-22 A | 2010-02-22 A | P3R06BC FF, E3R06B30 FF | 100% |  | 555,052.5 | 555,052.5 | P3R06BD | P3R06BD | 860 | R06B | 00 |  | 2RE1800 | 200 | 200 | 400 | P |  |  | LND | 0 | P | R | PR23 | LUZ1 | PI | LND |  |
| P3R06BL |  | R06B AG Pipes CS - Lead Time/Fabrication |  | 369d | 2010-02-23 A | 2011-03-02 A | F3120 FF, P3R06BD | 100% | TB26 - 2 - Manuf and Delivy |  |  | P3R06BL | P3R06BL | 860 | R06B | 00 |  | 2RE1800 | 200 | 200 | 400 | P |  | DEL | LND | 0 | P | R | PR26 | LUZ1 | PI | LND |  |
| P3R06D |  | R06 AG Fittings CS - 1st PO issued | milestone | 0d | 2010-02-25 A | 2010-02-25 A | F4650 FF, P3R06C FF, E3R0630 FF, F4620 FF | 100% |  | 183,148.75 | 183,148.75 | P3R06D | P3R06D | 860 | R06 | 00 |  | 2RE1820 | 200 | 200 | 400 | P |  |  | LND | 0 | P | R | PR23 | LUZ1 | PI | LND |  |
| P3R06DD |  | R06D AG Flanges CS/SS - 1st PO issued | milestone | 0d | 2010-02-25 A | 2010-02-25 A | E3R06D30 FF, P3R06DC FF | 100% |  | 267,321.25 | 267,321.25 | P3R06DD | P3R06DD | 860 | R06D | 00 |  | 2RE1840 | 200 | 200 | 400 | P |  |  | LND | 0 | P | R | PR23 | LUZ1 | PI | LND |  |
| P3R06DL |  | R06D AG Flanges CS/SS - Lead Time/Fabrication |  | 347d | 2010-02-26 A | 2011-02-11 A | P3R06DD, F3120 FF | 100% | TB26 - 2 - Manuf and Delivy |  |  | P3R06DL | P3R06DL | 860 | R06D | 00 |  | 2RE1840 | 200 | 200 | 400 | P |  | DEL | LND | 0 | P | R | PR26 | LUZ1 | PI | LND |  |
| P3R06L |  | R06 AG Fittings CS - Lead Time/Fabrication |  | 379d | 2010-02-26 A | 2011-03-15 A | F3120 FF, P3R06D | 100% | TB26 - 2 - Manuf and Delivy |  |  | P3R06L | P3R06L | 860 | R06 | 00 |  | 2RE1820 | 200 | 200 | 400 | P |  | DEL | LND | 0 | P | R | PR26 | LUZ1 | PI | LND |  |
| P3R07AA |  | R07A Standard Pipe Supp. - Prepare/Issue RFQ |  | 4d | 2010-02-26 A | 2010-03-03 A | E3R07A10 | 100% |  |  |  | P3R07AA | P3R07AA | 860 | R07A | 00 |  | 2RE2190 | 200 | 200 | 400 | P |  | DEV | LND | 0 | P | R | PR21 | LUZ1 | PI | LND |  |
| P3R07AB |  | R07A Standard Pipe Supp. - RFQ issued | milestone | 0d | 2010-03-03 A | 2010-03-03 A | P3R07AA FF | 100% |  | 53,921 | 53,921 | P3R07AB | P3R07AB | 860 | R07A | 00 |  | 2RE2190 | 200 | 200 | 400 | P |  | DEV | LND | 0 | P | R | PR21 | LUZ1 | PI | LND |  |
| P3R04D |  | R04 AG Gate Valves - 1st PO issued | milestone | 0d | 2010-03-09 A | 2010-03-09 A | A1010032, E3R0430 FF, P3R04C FF | 100% |  | 959,831.25 | 959,831.25 | P3R04D | P3R04D | 860 | R04 | 00 |  | 2AC2600 | 200 | 200 | 400 | P |  |  | LND | 0 | P | R | PR23 | LUZ1 | PI | LND |  |
| P3R04L |  | R04 AG Gate Valves - Lead Time/Fabrication |  | 412d | 2010-03-10 A | 2011-04-29 A | P3R04D | 100% | TB26 - 2 - Manuf and Delivy |  |  | P3R04L | P3R04L | 860 | R04 | 00 |  | 2AC2600 | 200 | 200 | 400 | P |  | DEL | LND | 0 | P | R | PR26 | LUZ1 | PI | LND |  |
| P3R06AD |  | R06A AG Fittings SS - 1st PO issued | milestone | 0d | 2010-04-01 A | 2010-04-01 A | E3R06A30 FF, P3R06AC FF | 100% |  | 76,667.5 | 76,667.5 | P3R06AD | P3R06AD | 860 | R06A | 00 |  | 2RE1830 | 200 | 200 | 400 | P |  |  | LND | 0 | P | R | PR23 | LUZ1 | PI | LND |  |
| P3R06AL |  | R06A AG Fittings SS - Lead Time/Fabrication |  | 329d | 2010-04-02 A | 2011-02-28 A | P3R06AD, F3120 FF | 100% | TB26 - 2 - Manuf and Delivy |  |  | P3R06AL | P3R06AL | 860 | R06A | 00 |  | 2RE1830 | 200 | 200 | 400 | P |  | DEL | LND | 0 | P | R | PR26 | LUZ1 | PI | LND |  |
| P3R04AA |  | R04A Piston RAM Valves - Prepare/Issue RFQ |  | 4d | 2010-04-06 A | 2010-04-09 A | E3R04A10 | 100% |  |  |  | P3R04AA | P3R04AA | 860 | R04A | 00 |  | 2AC5490 | 200 | 200 | 400 | P |  | DEV | LND | 0 | P | R | PR21 | LUZ1 | PI | LND |  |
| P3R06CD |  | R06C AG Pipes SS - 1st PO issued | milestone | 0d | 2010-04-06 A | 2010-04-06 A | P3R06CC FF, E3R06C30 FF | 100% |  | 389,370 | 389,370 | P3R06CD | P3R06CD | 860 | R06C | 00 |  | 2RE1810 | 200 | 200 | 400 | P |  |  | LND | 0 | P | R | PR23 | LUZ1 | PI | LND |  |
| P3R06CL |  | R06C AG Pipes SS - Lead Time/Fabrication |  | 321d | 2010-04-07 A | 2011-02-25 A | F3120 FF, P3R06CD | 100% | TB26 - 2 - Manuf and Delivy |  |  | P3R06CL | P3R06CL | 860 | R06C | 00 |  | 2RE1810 | 200 | 200 | 400 | P |  | DEL | LND | 0 | P | R | PR26 | LUZ1 | PI | LND |  |
| P3R04AB |  | R04A Piston RAM Valves - RFQ issued | milestone | 0d | 2010-04-09 A | 2010-04-09 A | P3R04AA FF | 100% |  | 10,450 | 10,450 | P3R04AB | P3R04AB | 860 | R04A | 00 |  | 2AC5490 | 200 | 200 | 400 | P |  | DEV | LND | 0 | P | R | PR21 | LUZ1 | PI | LND |  |
| P3R09BA |  | R09B Air Manifolds - Prepare/Issue RFQ |  | 5d | 2010-04-12 A | 2010-04-16 A | E3R09B10 | 100% |  |  |  | P3R09BA | P3R09BA | 860 | R09B | 00 |  | 2RE2220 | 200 | 200 | 400 | P |  | DEV | LND | 0 | P | R | PR21 | LUZ1 | PI | LND |  |

Notes:
- P3ALL1B: Expenses: 900A 257425
- P3ALL1D: Expenses: 900A 1029700
- P3ALL1L: P3 Activity Log Info: 19 / month
- P3ALL1X: Expenses: 900A 1544550
- P3ALL1M: Expenses: 900A 772275
- P3ALL1N: P3 Activity Log Info: Ship Archangelsk (15days) /Ship / Tobolsk (15days) Custom Clearance (30days)
- P3ALL1N1: P3 Activity Log Info: North / Sea
- P3ALL1N3: P3 Activity Log Info: River / (Irtysch/Tobol)
- P3R04B: Expenses: 900A 191966
- P3R06AB: Expenses: 900A 15333.5
- P3R06B: Expenses: 900A 36629.8
- P3R06BB: Expenses: 900A 111010
- P3R06CB: Expenses: 900A 77874
- P3R06DB: Expenses: 900A 53464.2
- P3R02B: Expenses: 900A 46649
- P3R02AB: Expenses: 900A 46649
- P3R06BD: Expenses: 900A 555052
- P3R06D: Expenses: 900A 183149
- P3R06DD: Expenses: 900A 267321
- P3R07AB: Expenses: 900A 53921
- P3R04D: Expenses: 900A 959831
- P3R06AD: Expenses: 900A 76667.5
- P3R06CD: Expenses: 900A 389370
- P3R04AB: Expenses: 900A 10450

| ID | Activity | Type | Duration | Start | Finish | Predecessors | Complete | Calendar | Cost | Actual cost | UDF_SAVE ACTID | UDF_SAVE ACT ID | Department | Type of Work | Constr. Area | Inquiry/Order No | PMT-Area | PMT-Schedule Org | PMT-Discipline | PMT-Phase | PMT-Doc. Type | PMT-Respons. | Zeigen/n. Zeigen | WBS Phase | WBS Discipline | WBS Type of Work | WBS Objects | IMS | UPT |
| --- | --- | --- | --- | --- | --- | --- | --- | --- | --- | --- | --- | --- | --- | --- | --- | --- | --- | --- | --- | --- | --- | --- | --- | --- | --- | --- | --- | --- | --- |
| P3R09BB | R09B Air Manifolds - RFQ issued | milestone | 0d | 2010-04-16 A | 2010-04-16 A | P3R09BA FF | 100% |  | 22,247.5 | 22,247.5 | P3R09BB | P3R09BB | 860 | R09B | 00 | 2RE2220 | 200 | 200 | 400 | P | DEV | LND | 0 | P | R | PR21 | LUZ1 | PI | LND |
| P3R07AC | R07A Standard Pipe Supp. - Eval./Negotiation |  | 59d | 2010-04-19 A | 2010-07-12 A | E3R07A20 FF, P3R07AB | 100% |  |  |  | P3R07AC | P3R07AC | 860 | R07A | 00 | 2RE2190 | 200 | 200 | 400 | P |  | LND | 0 | P | R | PR22 | LUZ1 | PI | LND |
| P3R04AC | R04A Piston RAM Valves - Eval./Negotiation |  | 59d | 2010-05-25 A | 2010-08-13 A | P3R04AB, E3R04A20 FF | 100% |  |  |  | P3R04AC | P3R04AC | 860 | R04A | 00 | 2AC5490 | 200 | 200 | 400 | P |  | LND | 0 | P | R | PR22 | LUZ1 | PI | LND |
| P3R02D | R02 UG GFK Pipes - 1st PO issued (depends on client) | milestone | 0d | 2010-06-04 A | 2010-06-04 A | E3R0230 FF, P3R02C FF, F4020 FF | 100% |  | 233,245 | 233,245 | P3R02D | P3R02D | 860 | R02 | 00 | 2RE1350 | 200 | 200 | 400 | P |  | LND | C5 | P | R | PR23 | LUZ1 | PI | LND |
| P3R02L | R02 UG GFK Pipes - Lead Time/Fabrication |  | 240d | 2010-06-05 A | 2011-02-02 A | P3R02D | 100% | TB26 - 2 - Manuf and Delivy |  |  | P3R02L | P3R02L | 860 | R02 | 00 | 2RE1350 | 200 | 200 | 400 | P | DEL | LND | C5 | P | R | PR26 | LUZ1 | PI | LND |
| P3R09BC | R09B Air Manifolds - Eval./Negotiation |  | 53d | 2010-06-08 A | 2010-08-19 A | E3R09B20 FF, P3R09BB | 100% |  |  |  | P3R09BC | P3R09BC | 860 | R09B | 00 | 2RE2220 | 200 | 200 | 400 | P |  | LND | 0 | P | R | PR22 | LUZ1 | PI | LND |
| P3R02AD | R02A UG Cast Iron Pipes - 1st PO issued (depends on client) | milestone | 0d | 2010-06-14 A | 2010-06-14 A | F4020 FF, P3R02AC FF, E3R02A30 FF | 100% |  | 233,245 | 233,245 | P3R02AD | P3R02AD | 860 | R02A | 00 | 2RE2240 | 200 | 200 | 400 | P |  | LND | C5 | P | R | PR23 | LUZ1 | PI | LND |
| P3R02AL | R02A UG Cast Iron Pipes - Lead Time/Fabrication |  | 347d | 2010-06-15 A | 2011-05-31 A | P3R02AD | 100% | TB26 - 2 - Manuf and Delivy |  |  | P3R02AL | P3R02AL | 860 | R02A | 00 | 2RE2240 | 200 | 200 | 400 | P | DEL | LND | C5 | P | R | PR26 | LUZ1 | PI | LND |
| P3R06BX | R06B AG Pipes CS - Final Inspection | milestone | 0d | 2010-06-15 A | 2010-06-15 A | P3R06BL SF+112d | 100% | TB26 - 2 - Manuf and Delivy | 999,094.5 | 999,094.5 | P3R06BX | P3R06BX | 860 | R06B | 00 | 2RE1800 | 200 | 200 | 400 | P |  | LND | 0 | P | R | PR27 | LUZ1 | PI | LND |
| P3R06BM | R06B AG Pipes CS - Material deliv. FOB |  | 262d | 2010-06-21 A | 2011-03-12 A | P3R06BL FF+10d, P3R06BX FS+5d | 100% | TB26 - 2 - Manuf and Delivy |  |  | P3R06BM | P3R06BM | 860 | R06B | 00 | 2RE1800 | 200 | 200 | 400 | P |  | LND | 0 | P | R | PR28 | LUZ1 | PI | LND |
| P3R06BM1 | R06B AG Pipes CS - 1st Material deliv. FOB | milestone | 0d | 2010-06-21 A | 2010-06-21 A | P3R06BM SF+1d | 100% | TB26 - 2 - Manuf and Delivy | 333,031.5 | 333,031.5 | P3R06BM1 | P3R06BM1 | 860 | R06B | 00 | 2RE1800 | 200 | 200 | 400 | P |  | LND | 0 | P | R | PR28 | LUZ1 | PI | LND |
| P3R02AG | R02A Gost R Certificate to russ. customs | milestone | 0d | 2010-06-27 A | 2010-06-27 A | P3R02AN SF-20d | 100% | TB26 - 2 - Manuf and Delivy |  |  | P3R02AG | P3R02AG | 860 | R02A | 00 | 2RE2240 | 200 | 200 | 400 | P |  | LND | 0 | P | R | PR28 | LUZ1 | PI | LND |
| P3R06DX | R06D AG Flanges CS/SS - Final Inspection | milestone | 0d | 2010-06-29 A | 2010-06-29 A | P3R06DL SF+123d | 100% | TB26 - 2 - Manuf and Delivy | 481,178.25 | 481,178.25 | P3R06DX | P3R06DX | 860 | R06D | 00 | 2RE1840 | 200 | 200 | 400 | P |  | LND | 0 | P | R | PR27 | LUZ1 | PI | LND |
| P3R07AD | R07A Standard Pipe Supp. - 1st PO issued | milestone | 0d | 2010-07-12 A | 2010-07-12 A | E3R07A30 FF, P3R07AC FF | 100% |  | 269,606 | 269,606 | P3R07AD | P3R07AD | 860 | R07A | 00 | 2RE2190 | 200 | 200 | 400 | P |  | LND | 0 | P | R | PR23 | LUZ1 | PI | LND |
| P3R07AL | R07A Standard Pipe Supp. - Lead Time/Fabrication |  | 253d | 2010-07-13 A | 2011-03-25 A | F3120 FF, P3R07AD | 100% | TB26 - 2 - Manuf and Delivy |  |  | P3R07AL | P3R07AL | 860 | R07A | 00 | 2RE2190 | 200 | 200 | 400 | P | DEL | LND | 0 | P | R | PR26 | LUZ1 | PI | LND |
| P3R06DM | R06D AG Flanges CS/SS - Material deliv. FOB |  | 222d | 2010-07-15 A | 2011-02-24 A | P3R06DX FS+15d, P3R06DL FF+10d | 100% | TB26 - 2 - Manuf and Delivy |  |  | P3R06DM | P3R06DM | 860 | R06D | 00 | 2RE1840 | 200 | 200 | 400 | P |  | LND | 0 | P | R | PR28 | LUZ1 | PI | LND |
| P3R06DM1 | R06D AG Flanges CS/SS - 1st Material deliv. FOB | milestone | 0d | 2010-07-15 A | 2010-07-15 A | P3R06DM SF+1d | 100% | TB26 - 2 - Manuf and Delivy | 160,392.75 | 160,392.75 | P3R06DM1 | P3R06DM1 | 860 | R06D | 00 | 2RE1840 | 200 | 200 | 400 | P |  | LND | 0 | P | R | PR28 | LUZ1 | PI | LND |
| P3R03BA | R03B Gaskets - Prepare/Issue RFQ |  | 6d | 2010-07-23 A | 2010-07-30 A | E3R03B10 | 100% |  |  |  | P3R03BA | P3R03BA | 860 | R03B | 00 | 2RE2380 | 200 | 200 | 400 | P | DEV | LND | 0 | P | R | PR21 | LUZ1 | PI | LND |
| P3R02AX | R02A UG Cast Iron Pipes - Final Inspection | milestone | 0d | 2010-07-23 A | 2010-07-23 A | P3R02AL SF+39d | 100% | TB26 - 2 - Manuf and Delivy | 419,840 | 419,840 | P3R02AX | P3R02AX | 860 | R02A | 00 | 2RE2240 | 200 | 200 | 400 | P |  | LND | 0 | P | R | PR27 | LUZ1 | PI | LND |
| P3R03AA | R03A Bolting Material - Prepare/Issue RFQ |  | 5d | 2010-07-26 A | 2010-07-30 A | E3R03A10 | 100% |  |  |  | P3R03AA | P3R03AA | 860 | R03A | 00 | 2RE2610 | 200 | 200 | 400 | P | DEV | LND | 0 | P | R | PR21 | LUZ1 | PI | LND |
| P3R02G | R02 Gost R Certificate to russ. customs | milestone | 0d | 2010-07-28 A | 2010-07-28 A | P3R02N SF-20d | 100% | TB26 - 2 - Manuf and Delivy |  |  | P3R02G | P3R02G | 860 | R02 | 00 | 2RE1350 | 200 | 200 | 400 | P |  | LND | 0 | P | R | PR28 | LUZ1 | PI | LND |
| P3R06X | R06 AG Fittings CS - Final Inspection | milestone | 0d | 2010-07-28 A | 2010-07-28 A | P3R06L SF+152d | 100% | TB26 - 2 - Manuf and Delivy | 329,667.75 | 329,667.75 | P3R06X | P3R06X | 860 | R06 | 00 | 2RE1820 | 200 | 200 | 400 | P |  | LND | 0 | P | R | PR27 | LUZ1 | PI | LND |
| P3R02AM | R02A UG Cast Iron Pipes - Material deliv. FOB |  | 319d | 2010-07-29 A | 2011-06-16 A | P3R02AX FS+5d, P3R02AL FF+10d | 100% | TB26 - 2 - Manuf and Delivy |  |  | P3R02AM | P3R02AM | 860 | R02A | 00 | 2RE2240 | 200 | 200 | 400 | P |  | LND | C5 | P | R | PR28 | LUZ1 | PI | LND |
| P3R02AM1 | R02A UG Cast Iron Pipes - 1st Material deliv. FOB | milestone | 0d | 2010-07-29 A | 2010-07-29 A | P3R02AM SF+1d | 100% | TB26 - 2 - Manuf and Delivy | 139,946 | 139,946 | P3R02AM1 | P3R02AM1 | 860 | R02A | 00 | 2RE2240 | 200 | 200 | 400 | P |  | LND | C5 | P | R | PR28 | LUZ1 | PI | LND |
| P3R03AB | R03A Bolting Material - RFQ issued | milestone | 0d | 2010-07-30 A | 2010-07-30 A | P3R03AA FF | 100% |  | 18,618 | 18,618 | P3R03AB | P3R03AB | 860 | R03A | 00 | 2RE2610 | 200 | 200 | 400 | P | DEV | LND | 0 | P | R | PR21 | LUZ1 | PI | LND |
| P3R03BB | R03B Gaskets - RFQ issued | milestone | 0d | 2010-07-30 A | 2010-07-30 A | P3R03BA FF | 100% |  | 8,463.5 | 8,463.5 | P3R03BB | P3R03BB | 860 | R03B | 00 | 2RE2380 | 200 | 200 | 400 | P | DEV | LND | 0 | P | R | PR21 | LUZ1 | PI | LND |
| P3R02X | R02 UG GFK Pipes - Final Inspection | milestone | 0d | 2010-08-12 A | 2010-08-12 A | P3R02L SF+69d | 100% | TB26 - 2 - Manuf and Delivy | 419,840 | 419,840 | P3R02X | P3R02X | 860 | R02 | 00 | 2RE1350 | 200 | 200 | 400 | P |  | LND | 0 | P | R | PR27 | LUZ1 | PI | LND |
| P3R06M | R06 AG Fittings CS - Material deliv. FOB |  | 222d | 2010-08-13 A | 2011-03-25 A | P3R06L FF+10d, P3R06X FS+15d | 100% | TB26 - 2 - Manuf and Delivy |  |  | P3R06M | P3R06M | 860 | R06 | 00 | 2RE1820 | 200 | 200 | 400 | P |  | LND | 0 | P | R | PR28 | LUZ1 | PI | LND |
| P3R04AD | R04A Piston RAM Valves - PO issued | milestone | 0d | 2010-08-13 A | 2010-08-13 A | P3R04AC FF, E3R04A30 FF | 100% |  | 52,250 | 52,250 | P3R04AD | P3R04AD | 860 | R04A | 00 | 2AC5490 | 200 | 200 | 400 | P |  | LND | 0 | P | R | PR23 | LUZ1 | PI | LND |
| P3R06M1 | R06 AG Fittings CS - 1st Material deliv. FOB | milestone | 0d | 2010-08-13 A | 2010-08-13 A | P3R06M SF+1d | 100% | TB26 - 2 - Manuf and Delivy | 109,889.25 | 109,889.25 | P3R06M1 | P3R06M1 | 860 | R06 | 00 | 2RE1820 | 200 | 200 | 400 | P |  | LND | 0 | P | R | PR28 | LUZ1 | PI | LND |
| P3R04AL | R04A Piston RAM Valves - Lead Time/Fabrication |  | 151d | 2010-08-14 A | 2011-01-14 A | P3R04AD | 100% | TB26 - 2 - Manuf and Delivy |  |  | P3R04AL | P3R04AL | 860 | R04A | 00 | 2AC5490 | 200 | 200 | 400 | P | DEL | LND | 0 | P | R | PR26 | LUZ1 | PI | LND |
| P3R09BD | R09B Air Manifolds - 1st PO issued | milestone | 0d | 2010-08-19 A | 2010-08-19 A | E3R09B30 FF, P3R09BC FF | 100% |  | 111,237.5 | 111,237.5 | P3R09BD | P3R09BD | 860 | R09B | 00 | 2RE2220 | 200 | 200 | 400 | P |  | LND | 0 | P | R | PR23 | LUZ1 | PI | LND |
| P3R09BL | R09B Air Manifolds - Lead Time/Fabrication |  | 162d | 2010-08-20 A | 2011-01-31 A | P3R09BD | 100% | TB26 - 2 - Manuf and Delivy |  |  | P3R09BL | P3R09BL | 860 | R09B | 00 | 2RE2220 | 200 | 200 | 400 | P | DEL | LND | 0 | P | R | PR26 | LUZ1 | PI | LND |
| P3R02M | R02 UG GFK Pipes - Material deliv. FOB |  | 171d | 2010-08-23 A | 2011-02-12 A | P3R02L FF+10d, P3R02X FS+10d | 100% | TB26 - 2 - Manuf and Delivy |  |  | P3R02M | P3R02M | 860 | R02 | 00 | 2RE1350 | 200 | 200 | 400 | P |  | LND | C5 | P | R | PR28 | LUZ1 | PI | LND |
| P3R02M1 | R02 UG GFK Pipes - 1st Material deliv. FOB | milestone | 0d | 2010-08-23 A | 2010-08-23 A | P3R02M SF+1d | 100% | TB26 - 2 - Manuf and Delivy | 139,946 | 139,946 | P3R02M1 | P3R02M1 | 860 | R02 | 00 | 2RE1350 | 200 | 200 | 400 | P |  | LND | C5 | P | R | PR28 | LUZ1 | PI | LND |
| P3R03AC | R03A Bolting Material - Eval./Negotiation |  | 78d | 2010-08-25 A | 2010-12-13 A | A1KL1135 FF, P3R03AB, E3R03A20 FF | 100% |  |  |  | P3R03AC | P3R03AC | 860 | R03A | 00 | 2RE2610 | 200 | 200 | 400 | P |  | LND | 0 | P | R | PR22 | LUZ1 | PI | LND |
| P3R06CX | R06C AG Pipes SS - Final Inspection | milestone | 0d | 2010-08-27 A | 2010-08-27 A | P3R06CL SF+142d | 100% | TB26 - 2 - Manuf and Delivy | 700,866 | 700,866 | P3R06CX | P3R06CX | 860 | R06C | 00 | 2RE1810 | 200 | 200 | 400 | P |  | LND | 0 | P | R | PR27 | LUZ1 | PI | LND |
| P3R01A | R01 UG Post Ind. Valves - Prepare/Issue RFQ |  | 5d | 2010-09-06 A | 2010-09-10 A | E3R0110 | 100% |  |  |  | P3R01A | P3R01A | 860 | R01 | 00 | 2AC2690 | 200 | 200 | 400 | P | DEV | LND | 0 | P | R | PR21 | LUZ1 | PI | LND |
| P3R03BC | R03B Gaskets - Eval./Negotiation |  | 69d | 2010-09-06 A | 2010-12-10 A | E3R03B20 FF, P3R03BB | 100% |  |  |  | P3R03BC | P3R03BC | 860 | R03B | 00 | 2RE2380 | 200 | 200 | 400 | P |  | LND | 0 | P | R | PR22 | LUZ1 | PI | LND |
| P3R01B | R01 UG Post Ind. Valves - RFQ issued | milestone | 0d | 2010-09-10 A | 2010-09-10 A | P3R01A FF | 100% |  | 31,702.25 | 31,702.25 | P3R01B | P3R01B | 860 | R01 | 00 | 2AC2690 | 200 | 200 | 400 | P | DEV | LND | 0 | P | R | PR21 | LUZ1 | PI | LND |
| P3R06BN | R06B AG Pipes CS - Transport to Site depends on prov. TSF Area |  | 207d | 2010-09-14 A | 2011-04-11 A | P3R06BM1, P3R06BM FF+30d, P3R100 FF, P3D1000 (other project) FS+5d, P3D1010 | 100% | TB26 - 2 - Manuf and Delivy |  |  | P3R06BN | P3R06BN | 860 | R06B | 00 | 2RE1800 | 200 | 200 | 400 | P |  | LND | 0 | P | R | PR28 | LUZ1 | PI | LND |
| P3R06CM | R06C AG Pipes SS - Material deliv. FOB |  | 170d | 2010-09-16 A | 2011-03-07 A | P3R06CL FF+10d, P3R06CX FS+10d | 100% | TB26 - 2 - Manuf and Delivy |  |  | P3R06CM | P3R06CM | 860 | R06C | 00 | 2RE1810 | 200 | 200 | 400 | P |  | LND | 0 | P | R | PR28 | LUZ1 | PI | LND |
| P3R06CM1 | R06C AG Pipes SS - 1st Material deliv. FOB | milestone | 0d | 2010-09-16 A | 2010-09-16 A | P3R06CM SF+1d | 100% | TB26 - 2 - Manuf and Delivy | 233,622 | 233,622 | P3R06CM1 | P3R06CM1 | 860 | R06C | 00 | 2RE1810 | 200 | 200 | 400 | P |  | LND | 0 | P | R | PR28 | LUZ1 | PI | LND |
| P3R06DN | R06D AG Flanges CS/SS - Transport to Site depends on prov. TSF Area |  | 194d | 2010-09-17 A | 2011-04-01 A | P3D1000 (other project) FS+5d, P3R06DM FF+30d, P3D1010, P3R100 FF, P3R06DM1 | 100% | TB26 - 2 - Manuf and Delivy |  |  | P3R06DN | P3R06DN | 860 | R06D | 00 | 2RE1840 | 200 | 200 | 400 | P |  | LND | 0 | P | R | PR28 | LUZ1 | PI | LND |
| P3R06AX | R06A AG Fittings SS - Final Inspection | milestone | 0d | 2010-09-24 A | 2010-09-24 A | P3R06AL SF+175d | 100% | TB26 - 2 - Manuf and Delivy | 138,001.5 | 138,001.5 | P3R06AX | P3R06AX | 860 | R06A | 00 | 2RE1830 | 200 | 200 | 400 | P |  | LND | 0 | P | R | PR27 | LUZ1 | PI | LND |
| P3R02AN | R02A UG Cast Iron Pipes - Transport to Site, depends on clar. custom clearance code |  | 285d | 2010-10-01 A | 2011-07-16 A | P3D1000 (other project), P3R02AM FF+30d, P3R02AM1, P3R110 FF | 100% | TB26 - 2 - Manuf and Delivy |  |  | P3R02AN | P3R02AN | 860 | R02A | 00 | 2RE2240 | 200 | 200 | 400 | P |  | LND | C5 | P | R | PR28 | LUZ1 | PI | LND |
| P3R06AM | R06A AG Fittings SS - Material deliv. FOB |  | 173d | 2010-10-01 A | 2011-03-25 A | P3R06AX FS+5d, P3R06AL FF+11d | 100% | TB26 - 2 - Manuf and Delivy |  |  | P3R06AM | P3R06AM | 860 | R06A | 00 | 2RE1830 | 200 | 200 | 400 | P |  | LND | 0 | P | R | PR28 | LUZ1 | PI | LND |
| P3R06AM1 | R06A AG Fittings SS - 1st Material deliv. FOB | milestone | 0d | 2010-10-01 A | 2010-10-01 A | P3R06AM SF+1d | 100% | TB26 - 2 - Manuf and Delivy | 46,000.5 | 46,000.5 | P3R06AM1 | P3R06AM1 | 860 | R06A | 00 | 2RE1830 | 200 | 200 | 400 | P |  | LND | 0 | P | R | PR28 | LUZ1 | PI | LND |
| P3R06N | R06 AG Fittings CS - Transport to Site depends on prov. TSF Area |  | 195d | 2010-10-04 A | 2011-04-19 A | P3R06M FF+20d, P3D1010, P3R100 FF, P3D1000 (other project) FS+5d, P3R06M1 | 100% | TB26 - 2 - Manuf and Delivy |  |  | P3R06N | P3R06N | 860 | R06 | 00 | 2RE1820 | 200 | 200 | 400 | P |  | LND | 0 | P | R | PR28 | LUZ1 | PI | LND |
| P3R07AX | R07A Standard Pipe Supp. - Final Inspection | milestone | 0d | 2010-10-10 A | 2010-10-10 A | P3R07AL SF+90d | 100% | TB26 - 2 - Manuf and Delivy | 485,292 | 485,292 | P3R07AX | P3R07AX | 860 | R07A | 00 | 2RE2190 | 200 | 200 | 400 | P |  | LND | 0 | P | R | PR27 | LUZ1 | PI | LND |
| P3R01C | R01 UG Post Ind. Valves - Eval./Negotiation |  | 82d | 2010-10-11 A | 2011-02-04 A | P3R01B, E3R0120 FF | 100% |  |  |  | P3R01C | P3R01C | 860 | R01 | 00 | 2AC2690 | 200 | 200 | 400 | P |  | LND | 0 | P | R | PR22 | LUZ1 | PI | LND |
| P3R06AN | R06A AG Fittings SS - Transport to Site depends on prov. TSF Area |  | 183d | 2010-10-16 A | 2011-04-19 A | P3D1010, P3R100 FF, P3D1000 (other project), P3R06AM FF+25d, P3R06AM1 | 100% | TB26 - 2 - Manuf and Delivy |  |  | P3R06AN | P3R06AN | 860 | R06A | 00 | 2RE1830 | 200 | 200 | 400 | P |  | LND | 0 | P | R | PR28 | LUZ1 | PI | LND |
| P3R02N | R02 UG GFK Pipes - Transport to Site, depends on clar. custom clearance code |  | 145d | 2010-10-18 A | 2011-03-14 A | P3R02M FF+30d, P3R02M1, P3R110 FF | 100% | TB26 - 2 - Manuf and Delivy |  |  | P3R02N | P3R02N | 860 | R02 | 00 | 2RE1350 | 200 | 200 | 400 | P |  | LND | C5 | P | R | PR28 | LUZ1 | PI | LND |
| P3R06CN | R06C AG Pipes SS - Transport to Site depends on clar. custom clearance code |  | 165d | 2010-10-21 A | 2011-04-06 A | P3R06CM FF+30d, P3D1010, P3R100 FF, P3R06CM1, P3D1000 (other project) | 100% | TB26 - 2 - Manuf and Delivy |  |  | P3R06CN | P3R06CN | 860 | R06C | 00 | 2RE1810 | 200 | 200 | 400 | P |  | LND | 0 | P | R | PR28 | LUZ1 | PI | LND |
| P3R07AM | R07A Standard Pipe Supp. - Material deliv. FOB |  | 174d | 2010-10-26 A | 2011-04-20 A | P3R07AL FF+10d, P3R07AX FS+15d | 100% | TB26 - 2 - Manuf and Delivy |  |  | P3R07AM | P3R07AM | 860 | R07A | 00 | 2RE2190 | 200 | 200 | 400 | P |  | LND | 0 | P | R | PR28 | LUZ1 | PI | LND |
| P3R04X | R04 AG Gate Valves - Final Inspection | milestone | 0d | 2010-10-26 A | 2010-10-26 A | P3R04L SF+230d | 100% | TB26 - 2 - Manuf and Delivy | 1,727,696.25 | 1,727,696.25 | P3R04X | P3R04X | 860 | R04 | 00 | 2AC2600 | 200 | 200 | 400 | P |  | LND | 0 | P | R | PR27 | LUZ1 | PI | LND |
| P3R07AM1 | R07A Standard Pipe Supp. - 1st Material deliv. FOB | milestone | 0d | 2010-10-26 A | 2010-10-26 A | P3R07AM SF+1d | 100% | TB26 - 2 - Manuf and Delivy | 161,764 | 161,764 | P3R07AM1 | P3R07AM1 | 860 | R07A | 00 | 2RE2190 | 200 | 200 | 400 | P |  | LND | 0 | P | R | PR28 | LUZ1 | PI | LND |
| P3R07AN | R07A Standard Pipe Supp. - Transport to Site |  | 203d | 2010-10-27 A | 2011-05-21 A | P3R07AM1, P3R07AM FF+30d | 100% | TB26 - 2 - Manuf and Delivy |  |  | P3R07AN | P3R07AN | 860 | R07A | 00 | 2RE2190 | 200 | 200 | 400 | P |  | LND | 0 | P | R | PR28 | LUZ1 | PI | LND |
| P3R07BA | R07B Special Pipe Supp. - Prepare/Issue RFQ |  | 3d | 2010-11-15 A | 2010-11-18 A | E3R07B10 | 100% |  |  |  | P3R07BA | P3R07BA | 860 | R07B | 00 | 2RE3370 | 200 | 200 | 400 | P | DEV | LND | 0 | P | R | PR21 | LUZ1 | PI | LND |
| P3R07BB | R07B Special Pipe Supp. - RFQ issued | milestone | 0d | 2010-11-18 A | 2010-11-18 A | P3R07BA FF | 100% |  | 9,673 | 9,673 | P3R07BB | P3R07BB | 860 | R07B | 00 | 2RE3370 | 200 | 200 | 400 | P | DEV | LND | 0 | P | R | PR21 | LUZ1 | PI | LND |
| P3R04M | R04 AG Gate Valves - Material deliv. FOB |  | 165d | 2010-11-26 A | 2011-05-13 A | P3R04X FS+30d, P3R04L FF+10d | 100% | TB26 - 2 - Manuf and Delivy |  |  | P3R04M | P3R04M | 860 | R04 | 00 | 2AC2600 | 200 | 200 | 400 | P |  | LND | 0 | P | R | PR28 | LUZ1 | PI | LND |
| P3R04M1 | R04 AG Gate Valves - 1st Material deliv. FOB | milestone | 0d | 2010-11-26 A | 2010-11-26 A | P3R04M SF+1d | 100% | TB26 - 2 - Manuf and Delivy | 575,898.75 | 575,898.75 | P3R04M1 | P3R04M1 | 860 | R04 | 00 | 2AC2600 | 200 | 200 | 400 | P |  | LND | 0 | P | R | PR28 | LUZ1 | PI | LND |
| P3R04N | R04 AG Gate Valves - Transport to Site |  | 189d | 2010-11-27 A | 2011-06-07 A | P3R04M1, P3R04M FF+25d | 100% | TB26 - 2 - Manuf and Delivy |  |  | P3R04N | P3R04N | 860 | R04 | 00 | 2AC2600 | 200 | 200 | 400 | P |  | LND | 0 | P | R | PR28 | LUZ1 | PI | LND |
| P3R03BD | R03B Gaskets - 1st PO issued | milestone | 0d | 2010-12-10 A | 2010-12-10 A | P3R03BC FF, E3R03B30 FF | 100% |  | 42,317.5 | 42,317.5 | P3R03BD | P3R03BD | 860 | R03B | 00 | 2RE2380 | 200 | 200 | 400 | P |  | LND | 0 | P | R | PR23 | LUZ1 | PI | LND |
| P3R03BL | R03B Gaskets - Lead Time/Fabrication |  | 88d | 2010-12-11 A | 2011-03-11 A | P3R03BD | 100% | TB26 - 2 - Manuf and Delivy |  |  | P3R03BL | P3R03BL | 860 | R03B | 00 | 2RE2380 | 200 | 200 | 400 | P | DEL | LND | 0 | P | R | PR26 | LUZ1 | PI | LND |
| P3R03AD | R03A Bolting Material - 1st PO issued | milestone | 0d | 2010-12-13 A | 2010-12-13 A | E3R03A30 FF, P3R03AC FF | 100% |  | 93,090 | 93,090 | P3R03AD | P3R03AD | 860 | R03A | 00 | 2RE2610 | 200 | 200 | 400 | P |  | LND | 0 | P | R | PR23 | LUZ1 | PI | LND |
| P3R03AL | R03A Bolting Material - Lead Time/Fabrication |  | 106d | 2010-12-14 A | 2011-04-01 A | P3R03AD | 100% | TB26 - 2 - Manuf and Delivy |  |  | P3R03AL | P3R03AL | 860 | R03A | 00 | 2RE2610 | 200 | 200 | 400 | P | DEL | LND | 0 | P | R | PR26 | LUZ1 | PI | LND |
| P3R09AA | R09A Expansion Joints - Prepare/Issue RFQ |  | 5d | 2010-12-14 A | 2010-12-20 A | E3R09A10 | 100% |  |  |  | P3R09AA | P3R09AA | 860 | R09A | 00 | R09A | 200 | 200 | 400 | P | DEV | LND | 0 | P | R | PR21 | LUZ1 | PI | LND |
| P3R09AB | R09A Expansion Joints - RFQ issued | milestone | 0d | 2010-12-20 A | 2010-12-20 A | P3R09AA FF | 100% |  | 9,191.25 | 9,191.25 | P3R09AB | P3R09AB | 860 | R09A | 00 | R09A | 200 | 200 | 400 | P | DEV | LND | 0 | P | R | PR21 | LUZ1 | PI | LND |
| P3R07BC | R07B Special Pipe Supp. - Eval./Negotiation |  | 58d | 2010-12-27 A | 2011-03-17 A | E3R07B20 FF, P3R07BB | 100% |  |  |  | P3R07BC | P3R07BC | 860 | R07B | 00 | 2RE3370 | 200 | 200 | 400 | P |  | LND | 0 | P | R | PR22 | LUZ1 | PI | LND |

Notes:
- P3R09BB: Expenses: 900A 22247.5
- P3R02D: Expenses: 900A 233245
- P3R02AD: Expenses: 900A 233245
- P3R06BX: Expenses: 900A 999094
- P3R06BM1: Expenses: 900A 333032
- P3R06DX: Expenses: 900A 481178
- P3R07AD: Expenses: 900A 269606
- P3R06DM1: Expenses: 900A 160393
- P3R02AX: Expenses: 900A 419840
- P3R06X: Expenses: 900A 329668
- P3R02AM1: Expenses: 900A 139946
- P3R03AB: Expenses: 900A 18618
- P3R03BB: Expenses: 900A 8463.5
- P3R02X: Expenses: 900A 419840
- P3R04AD: Expenses: 900A 52250
- P3R06M1: Expenses: 900A 109889
- P3R09BD: Expenses: 900A 111238
- P3R02M1: Expenses: 900A 139946
- P3R06CX: Expenses: 900A 700866
- P3R01B: Expenses: 900A 31702.2
- P3R06BN: P3 Activity Log Info: per / Train
- P3R06CM1: Expenses: 900A 233622
- P3R06DN: P3 Activity Log Info: per / Train
- P3R06AX: Expenses: 900A 138002
- P3R02AN: P3 Activity Log Info: per / Train
- P3R06AM1: Expenses: 900A 46000.5
- P3R06N: P3 Activity Log Info: per / Train
- P3R07AX: Expenses: 900A 485292
- P3R06AN: P3 Activity Log Info: per / Train
- P3R02N: P3 Activity Log Info: per / Train
- P3R06CN: P3 Activity Log Info: per / Train
- P3R04X: Expenses: 900A 1727696
- P3R07AM1: Expenses: 900A 161764
- P3R07AN: P3 Activity Log Info: per / Train
- P3R07BB: Expenses: 900A 9673
- P3R04M1: Expenses: 900A 575899
- P3R04N: P3 Activity Log Info: per / Train
- P3R03BD: Expenses: 900A 42317.5
- P3R03AD: Expenses: 900A 93090
- P3R09AB: Expenses: 900A 9191.25

| ID | Activity | Type | Duration | Start | Finish | Predecessors | Complete | Remaining | Total float | Free float | Constraint | Expected finish | Calendar | Cost | Actual cost | UDF_SAVE ACTID | UDF_SAVE ACT ID | Department | Type of Work | Constr. Area | Inquiry/Order No | PMT-Area | PMT-Schedule Org | PMT-Discipline | PMT-Phase | PMT-Respons. | Zeigen/n. Zeigen | WBS Phase | WBS Discipline | WBS Type of Work | WBS Objects | IMS | UPT | PMT-Doc. Type | UDF_CHECK BASELINE |
| --- | --- | --- | --- | --- | --- | --- | --- | --- | --- | --- | --- | --- | --- | --- | --- | --- | --- | --- | --- | --- | --- | --- | --- | --- | --- | --- | --- | --- | --- | --- | --- | --- | --- | --- | --- |
| P3R04AX | R04A Piston RAM Valves - Final Inspection | milestone | 0d | 2011-01-05 A | 2011-01-05 A | P3R04AL FF-10d | 100% |  |  |  |  |  | TB26 - 2 - Manuf and Delivy | 94,050 | 94,050 | P3R04AX | P3R04AX | 860 | R04A | 00 | 2AC5490 | 200 | 200 | 400 | P | LND | 0 | P | R | PR27 | LUZ1 | PI | LND |  |  |
| P3R04AM | R04A Piston RAM Valves - Material deliv. FCA/FOB | milestone | 0d | 2011-01-19 A | 2011-01-19 A | P3R04AL FF+5d, P3R04AX FS+10d | 100% |  |  |  |  |  | TB26 - 2 - Manuf and Delivy | 31,350 | 31,350 | P3R04AM | P3R04AM | 860 | R04A | 00 | 2AC5490 | 200 | 200 | 400 | P | LND | 0 | P | R | PR28 | LUZ1 | PI | LND |  |  |
| P3R09AC | R09A Expansion Joints - Eval./Negotiation |  | 86d | 2011-01-20 A | 2011-05-19 A | E3R09A20 FF, P3R09AB | 100% |  |  |  |  |  |  |  |  | P3R09AC | P3R09AC | 860 | R09A | 00 | R09A | 200 | 200 | 400 | P | LND | 0 | P | R | PR22 | LUZ1 | PI | LND |  |  |
| P3R09BX | R09B Air Manifolds - Final Inspection | milestone | 0d | 2011-01-21 A | 2011-01-21 A | P3R09BL FF-11d | 100% |  |  |  |  |  | TB26 - 2 - Manuf and Delivy | 200,227.5 | 200,227.5 | P3R09BX | P3R09BX | 860 | R09B | 00 | 2RE2220 | 200 | 200 | 400 | P | LND | 0 | P | R | PR27 | LUZ1 | PI | LND |  |  |
| P3R09BM | R09B Air Manifolds - Material deliv. FCA/FOB | milestone | 0d | 2011-01-31 A | 2011-01-31 A | P3R09BX, P3R09BL FF | 100% |  |  |  |  |  | TB26 - 2 - Manuf and Delivy | 66,742.5 | 66,742.5 | P3R09BM | P3R09BM | 860 | R09B | 00 | 2RE2220 | 200 | 200 | 400 | P | LND | 0 | P | R | PR28 | LUZ1 | PI | LND |  |  |
| P3R01D | R01 UG Post Ind. Valves - 1st PO issued | milestone | 0d | 2011-02-04 A | 2011-02-04 A | P3R01C FF, F4020 FF, E3R0130 FF, A1010032 | 100% |  |  |  |  |  |  | 158,511.25 | 158,511.25 | P3R01D | P3R01D | 860 | R01 | 00 | 2AC2690 | 200 | 200 | 400 | P | LND | 0 | P | R | PR23 | LUZ1 | PI | LND |  |  |
| P3R01L | R01 UG Post Ind. Valves - Lead Time/Fabrication |  | 188d | 2011-02-05 A | 2011-08-12 A | P3R01D | 100% |  |  |  |  |  | TB26 - 2 - Manuf and Delivy |  |  | P3R01L | P3R01L | 860 | R01 | 00 | 2AC2690 | 200 | 200 | 400 | P | LND | 0 | P | R | PR26 | LUZ1 | PI | LND | DEL |  |
| P3R02BD | R02B HDPE Pipes - PO issued | milestone | 0d | 2011-02-16 A | 2011-02-16 A | E3R02B30 FF, P3R02BC FF, F4020 FF | 100% |  |  |  |  |  |  |  |  | P3R02BD | P3R02BD | 860 | R02B | 00 | 2RE2290 | 200 | 200 | 400 | P | LND | 0 | P | R | PR23 | LUZ1 | PI | LND |  |  |
| P3R02BL | R02B HDPE Pipes - Lead Time/Fabrication |  | 78d | 2011-02-17 A | 2011-05-06 A | P3R02BD | 100% |  |  |  |  |  | TB26 - 2 - Manuf and Delivy |  |  | P3R02BL | P3R02BL | 860 | R02B | 00 | 2RE2290 | 200 | 200 | 400 | P | LND | 0 | P | R | PR26 | LUZ1 | PI | LND | DEL |  |
| P3R03BX | R03B Gaskets - Final Inspection | milestone | 0d | 2011-02-21 A | 2011-02-21 A | P3R03BL SF+70d | 100% |  |  |  |  |  | TB26 - 2 - Manuf and Delivy | 76,171.5 | 76,171.5 | P3R03BX | P3R03BX | 860 | R03B | 00 | 2RE2380 | 200 | 200 | 400 | P | LND | 0 | P | R | PR27 | LUZ1 | PI | LND |  |  |
| P3R03AX | R03A Bolting Material - Final Inspection | milestone | 0d | 2011-02-24 A | 2011-02-24 A | P3R03AL SF+70d | 100% |  |  |  |  |  | TB26 - 2 - Manuf and Delivy | 167,562 | 167,562 | P3R03AX | P3R03AX | 860 | R03A | 00 | 2RE2610 | 200 | 200 | 400 | P | LND | 0 | P | R | PR27 | LUZ1 | PI | LND |  |  |
| P3R04AN | R04A Piston RAM Valves - Transport to Site (collection of div. packages) |  | 25d | 2011-03-07 A | 2011-03-31 A | P3R04AM | 100% |  |  |  | start on or after 2011-03-07 |  | TB26 - 2 - Manuf and Delivy |  |  | P3R04AN | P3R04AN | 860 | R04A | 00 | 2AC5490 | 200 | 200 | 400 | P | LND | 0 | P | R | PR28 | LUZ1 | PI | LND |  |  |
| P3R07BD | R07B Special Pipe Supp. - 1st PO issued | milestone | 0d | 2011-03-17 A | 2011-03-17 A | E3R07B30 FF, P3R07BC FF | 100% |  |  |  |  |  |  | 48,364 | 48,364 | P3R07BD | P3R07BD | 860 | R07B | 00 | 2RE3370 | 200 | 200 | 400 | P | LND | 0 | P | R | PR23 | LUZ1 | PI | LND |  |  |
| P3R07BL | R07B Special Pipe Supp. - Lead Time/Fabrication |  | 63d | 2011-03-18 A | 2011-05-20 A | P3R07BD | 100% |  |  |  |  |  | TB26 - 2 - Manuf and Delivy |  |  | P3R07BL | P3R07BL | 860 | R07B | 00 | 2RE3370 | 200 | 200 | 400 | P | LND | 0 | P | R | PR26 | LUZ1 | PI | LND | DEL |  |
| P3R03BM1 | R03B Gaskets - 1st Material deliv. FOB | milestone | 0d | 2011-03-29 A | 2011-03-29 A | P3R03BL FS+10d | 100% |  |  |  |  |  | TB26 - 2 - Manuf and Delivy | 25,390.5 | 25,390.5 | P3R03BM1 | P3R03BM1 | 860 | R03B | 00 | 2RE2380 | 200 | 200 | 400 | P | LND | 0 | P | R | PR28 | LUZ1 | PI | LND |  |  |
| P3R03BN | R03B Gaskets - Transport to Site |  | 30d | 2011-03-29 A | 2011-04-27 A | P3R03BM1 FS-1d | 100% |  |  |  |  |  | TB26 - 2 - Manuf and Delivy |  |  | P3R03BN | P3R03BN | 860 | R03B | 00 | 2RE2380 | 200 | 200 | 400 | P | LND | 0 | P | R | PR28 | LUZ1 | PI | LND |  |  |
| P3R03AM1 | R03A Bolting Material - 1st Material deliv. FOB | milestone | 0d | 2011-04-04 A | 2011-04-04 A | P3R03AL FF+3d | 100% |  |  |  |  |  | TB26 - 2 - Manuf and Delivy | 55,854 | 55,854 | P3R03AM1 | P3R03AM1 | 860 | R03A | 00 | 2RE2610 | 200 | 200 | 400 | P | LND | 0 | P | R | PR28 | LUZ1 | PI | LND |  |  |
| P3R03AN | R03A Bolting Material - Transport to Site |  | 25d | 2011-04-05 A | 2011-04-29 A | P3R03AM1 | 100% |  |  |  |  |  | TB26 - 2 - Manuf and Delivy |  |  | P3R03AN | P3R03AN | 860 | R03A | 00 | 2RE2610 | 200 | 200 | 400 | P | LND | 0 | P | R | PR28 | LUZ1 | PI | LND |  |  |
| P3R07BX | R07B Special Pipe Supp. - Final Inspection | milestone | 0d | 2011-04-28 A | 2011-04-28 A | P3R07BL FF-4d | 100% |  |  |  |  |  | TB26 - 2 - Manuf and Delivy | 87,054 | 87,054 | P3R07BX | P3R07BX | 860 | R07B | 00 | 2RE3370 | 200 | 200 | 400 | P | LND | 0 | P | R | PR27 | LUZ1 | PI | LND |  |  |
| P3R02BX | R02B HDPE Pipes - Final Inspection | milestone | 0d | 2011-05-06 A | 2011-05-06 A | P3R02BL FF | 100% |  |  |  |  |  | TB26 - 2 - Manuf and Delivy |  |  | P3R02BX | P3R02BX | 860 | R02B | 00 | 2RE2290 | 200 | 200 | 400 | P | LND | 0 | P | R | PR27 | LUZ1 | PI | LND |  |  |
| P3R09AD | R09A Expansion Joints - 1st PO issued | milestone | 0d | 2011-05-19 A | 2011-05-19 A | P3R09AC FF, E3R09A30 FF | 100% |  |  |  |  |  |  | 45,956.25 | 45,956.25 | P3R09AD | P3R09AD | 860 | R09A | 00 | R09A | 200 | 200 | 400 | P | LND | 0 | P | R | PR23 | LUZ1 | PI | LND |  |  |
| P3R09AL | R09A Expansion Joints - Lead Time/Fabrication |  | 169d | 2011-05-20 A | 2011-11-04 | P3R09AD |  | 65d | 7d | 0d |  | 2011-11-04 | TB26 - 2 - Manuf and Delivy |  |  | P3R09AL | P3R09AL | 860 | R09A | 00 | R09A | 200 | 200 | 400 | P | LND | 0 | P | R | PR26 | LUZ1 | PI | LND | DEL |  |
| P3R02BM | R02B HDPE Pipes - Material deliv. FOB | milestone | 0d | 2011-05-21 A | 2011-05-21 A | P3R02BX, P3R02BL FS+15d | 100% |  |  |  |  |  | TB26 - 2 - Manuf and Delivy |  |  | P3R02BM1 | P3R02BM | 860 | R02B | 00 | 2RE2290 | 200 | 200 | 400 | P | LND | 0 | P | R | PR28 | LUZ1 | PI | LND |  |  |
| P3R02BN | R02B HDPE Pipes - Transport to Site |  | 25d | 2011-05-22 A | 2011-06-15 A | P3R110 FF, P3R02BM | 100% |  |  |  |  |  | TB26 - 2 - Manuf and Delivy |  |  | P3R02BN | P3R02BN | 860 | R02B | 00 | 2RE2290 | 200 | 200 | 400 | P | LND | 0 | P | R | PR28 | LUZ1 | PI | LND |  |  |
| P3R07BM | R07B Special Pipe Supp. - Material deliv. FOB/FCA | milestone | 0d | 2011-05-30 A | 2011-05-30 A | P3R07BL FF+10d | 100% |  |  |  |  |  | TB26 - 2 - Manuf and Delivy | 29,018 | 29,018 | P3R07BM1 | P3R07BM | 860 | R07B | 00 | 2RE3370 | 200 | 200 | 400 | P | LND | 0 | P | R | PR28 | LUZ1 | PI | LND |  | x |
| P3R01G | R01 Gost R Certificate to russ. customs | milestone | 0d | 2011-06-15 A | 2011-06-15 A | P3R01N FF-90d | 100% |  |  |  |  |  | TB26 - 2 - Manuf and Delivy |  |  | P3R01G | P3R01G | 860 | R01 | 00 | 2AC2690 | 200 | 200 | 400 | P | LND | 0 | P | R | PR28 | LUZ1 | PI | LND |  |  |
| P3R01X | R01 UG Post Ind. Valves - Final Inspection | milestone | 0d | 2011-08-03 A | 2011-08-03 A | P3R01L FF-10d, E3R0150 SF | 100% |  |  |  |  |  | TB26 - 2 - Manuf and Delivy | 285,320.25 | 285,320.25 | P3R01X | P3R01X | 860 | R01 | 00 | 2AC2690 | 200 | 200 | 400 | P | LND | 0 | P | R | PR27 | LUZ1 | PI | LND |  |  |
| P3R01M | R01 UG Post Ind. Valves - Goods deliv. FOB | milestone | 0d | 2011-08-27 A | 2011-08-27 A | P3R01L FF+15d, P3R01X FF | 100% |  |  |  |  |  | TB26 - 2 - Manuf and Delivy | 95,106.75 | 95,106.75 | P3R01M | P3R01M | 860 | R01 | 00 | 2AC2690 | 200 | 200 | 400 | P | LND | 0 | P | R | PR28 | LUZ1 | PI | LND |  |  |
| P3R01N | R01 UG Post Ind. Valves - Transport to Site |  | 30d | 2011-09-07 | 2011-10-06 | P3R01M FS+10d, P3R110 FF |  |  | 22d | 0d |  |  | TB26 - 2 - Manuf and Delivy |  |  | P3R01N | P3R01N | 860 | R01 | 00 | 2AC2690 | 200 | 200 | 400 | P | LND | 0 | P | R | PR28 | LUZ1 | PI | LND |  |  |
| P3R07BN | R07B Special Pipe Supp. - Transport to Site |  | 30d | 2011-09-18 | 2011-10-17 | P3R07BM FS+110d |  |  | -16d | 0d |  |  | TB26 - 2 - Manuf and Delivy |  |  | P3R07BN | P3R07BN | 860 | R07B | 00 | 2RE3370 | 200 | 200 | 400 | P | LND | 0 | P | R | PR28 | LUZ1 | PI | LND |  |  |
| P3R09BN | R09B Air Manifolds - Transport to Site collection of div. packages |  | 25d | 2011-09-19 | 2011-10-13 | P3R09BM FS+15d |  |  | -34d | 0d | start on 2011-09-19 |  | TB26 - 2 - Manuf and Delivy |  |  | P3R09BN | P3R09BN | 860 | R09B | 00 | 2RE2220 | 200 | 200 | 400 | P | LND | 0 | P | R | PR28 | LUZ1 | PI | LND |  |  |
| P3R09AX | R09A Expansion Joints - Final Inspection | milestone | 0d | 2011-10-26 | 2011-10-26 | P3R09AL FF-10d |  |  | 22d | 15d |  |  | TB26 - 2 - Manuf and Delivy | 82,721.25 |  | P3R09AX | P3R09AX | 860 | R09A | 00 | R09A | 200 | 200 | 400 | P | LND | 0 | P | R | PR27 | LUZ1 | PI | LND |  |  |
| P3R09AM | R09A Expansion Joints - Material deliv. FOB | milestone | 0d | 2011-11-09 | 2011-11-09 | P3R09AL FF+5d, P3R09AX |  |  | 7d | 0d |  |  | TB26 - 2 - Manuf and Delivy | 27,573.75 |  | P3R09AM | P3R09AM | 860 | R09A | 00 | R09A | 200 | 200 | 400 | P | LND | 0 | P | R | PR28 | LUZ1 | PI | LND |  |  |
| P3R09AN | R09A Expansion Joints - Transport to Site |  | 30d | 2011-11-10 | 2011-12-09 | P3R09AM |  |  | 7d | 0d |  |  | TB26 - 2 - Manuf and Delivy |  |  | P3R09AN | P3R09AN | 860 | R09A | 00 | R09A | 200 | 200 | 400 | P | OWN | 0 | P | R | PR28 | LUZ1 | PI | LND |  |  |

Notes:
- P3R04AX: Expenses: 900A 94050
- P3R04AM: Expenses: 900A 31350
- P3R09BX: Expenses: 900A 200228
- P3R09BM: Expenses: 900A 66742.5
- P3R01D: Expenses: 900A 158511
- P3R03BX: Expenses: 900A 76171.5
- P3R03AX: Expenses: 900A 167562
- P3R04AN: P3 Activity Log Info: per / Train
- P3R07BD: Expenses: 900A 48364
- P3R03BM1: Expenses: 900A 25390.5
- P3R03BN: P3 Activity Log Info: per / Train
- P3R03AM1: Expenses: 900A 55854
- P3R03AN: P3 Activity Log Info: per / Train
- P3R07BX: Expenses: 900A 87054
- P3R09AD: Expenses: 900A 45956.2
- P3R02BN: P3 Activity Log Info: per / Train
- P3R07BM: Expenses: 900A 29018
- P3R01X: Expenses: 900A 285320
- P3R01M: Expenses: 900A 95106.8
- P3R01N: P3 Activity Log Info: per / Train
- P3R07BN: P3 Activity Log Info: per / Train
- P3R09BN: P3 Activity Log Info: per / Train
- P3R09AX: Expenses: 900A 82721.2
- P3R09AM: Expenses: 900A 27573.8
- P3R09AN: P3 Activity Log Info: per / Train

| ID | WBS | Activity | Type | Duration | Start | Finish | Predecessors | Complete | Calendar | Cost | Actual cost | UDF_SAVE ACTID | UDF_SAVE ACT ID | Department | Type of Work | Constr. Area | Pro Unit/DocCode | Inquiry/Order No | PMT-Area | PMT-Schedule Org | PMT-Discipline | PMT-Phase | PMT-Stage | PMT-Doc. Type | PMT-Respons. | Zeigen/n. Zeigen | WBS Phase | WBS Discipline | WBS Type of Work | WBS Objects | IMS | UPT |
| --- | --- | --- | --- | --- | --- | --- | --- | --- | --- | --- | --- | --- | --- | --- | --- | --- | --- | --- | --- | --- | --- | --- | --- | --- | --- | --- | --- | --- | --- | --- | --- | --- |
|  | 1232 | **1232 Recycle Gas Compressor - CA12** |  |  | 2007-12-20 | 2011-01-17 |  |  |  |  |  |  |  |  |  |  |  |  |  |  |  |  |  |  |  |  |  |  |  |  |  |  |
|  | M | **M Mechanical - Rotating Equipment** |  |  | 2007-12-20 | 2011-01-17 |  |  |  |  |  |  |  |  |  |  |  |  |  |  |  |  |  |  |  |  |  |  |  |  |  |  |
| P3M02A |  | M02 Recycle Gas Compr. - Prepare Spec./Issue RFQ |  | 11d | 2007-12-20 A | 2008-01-10 A | F1540 SS, F1660 SS | 100% |  |  |  | P3M02A | P3M02A | 860 | M02 | 00 | DC | 2DC8490 | 200 | 200 | 400 | P | 3A | DEV | LND | C2 | P | M | PM11 | 1232 | E | LND |
| F6160 |  | M02 Recycle Gas Compr. - Vendor Bid Preparation |  | 21d | 2008-01-11 A | 2008-02-08 A | P3M02B | 100% |  |  |  | F6160 | F6160 | 860 | M02 | 00 | DC | 2DC8490 | 200 | 200 | 400 | P | 3A |  | LND | C2 | P | M | PM11 | 1232 | 1 | LND |
| F6270 |  | M02 Recycle Gas Compr. - Issue RFQ to PMT | milestone | 0d | 2008-01-11 A | 2008-01-11 A | P3M02B FF | 100% |  |  |  | F6270 | F6270 | 860 | M02 | 00 |  | 2DC8490 | 200 | 200 | 400 | P | 3A |  | LND | C2 | P | M | PM11 | 1232 | 1 | LND |
| F6280 |  | M02 Recycle Gas Compr. - PMT approve RFQ |  | 20d | 2008-01-11 A | 2008-02-07 A | F6270 | 100% |  |  |  | F6280 | F6280 | 860 | M02 | 00 |  | 2DC8490 | 200 | 200 | 400 | P | 3A |  | PMT | C2 | P | M | PM11 | 1232 | 1 | LND |
| P3M02B |  | M02 Recycle Gas Compr. - RFQ issued to bidders | milestone | 0d | 2008-01-11 A | 2008-01-11 A | P3M02A FF | 100% |  | 239,804 | 239,804 | P3M02B | P3M02B | 860 | M02 | 00 | DC | 2DC8490 | 200 | 200 | 400 | P | 3A |  | LND | C2 | P | M | PM11 | 1232 | E | LND |
| F6290 |  | M02 Recycle Gas Compr- Vendor Bid for INEOS Rev | milestone | 0d | 2008-02-08 A | 2008-02-08 A | F6280, F6160 | 100% |  |  |  | F6290 | F6290 | 860 | M02 | 00 |  | 2DC8490 | 200 | 200 | 400 | P | 3A |  | LND | C2 | P | M | PM12 | 1232 | 1 | LND |
| P3M02C |  | M02 Recycle Gas Compr. - Eval./Negotiation |  | 55d | 2008-03-07 A | 2008-05-28 A | F6210 | 100% |  |  |  | P3M02C | P3M02C | 860 | M02 | 00 | DC | 2DC8490 | 200 | 200 | 400 | P | 3A |  | LND | C2 | P | M | PM12 | 1232 | E | LND |
| F6340 |  | M02 Recycle Gas Compr. - Bid tab Client appr. |  | 6d | 2008-04-29 A | 2008-05-07 A | E3M0230, P3M02C FF | 100% |  |  |  | F6340 | F6340 | 860 | M02 | 00 |  | 2DC8490 | 200 | 200 | 400 | P | 3A |  | PMT | C2 | P | M | PM12 | 1232 | 1 | LND |
| P3M02D |  | M02 Recycle Gas Compr. - PO issued | milestone | 0d | 2008-05-29 A | 2008-05-29 A | E3M0220 FF, F6340 FF, F2930 FF | 100% |  | 959,216 | 959,216 | P3M02D | P3M02D | 860 | M02 | 00 | DC | 2DC8490 | 200 | 200 | 400 | P | 3A |  | LND | C2 | P | M | PM13 | 1232 | E | LND |
| P3M02L |  | M02 Recycle Gas Compr. - Lead Time/Fabrication |  | 587d | 2008-05-29 A | 2010-01-12 A | P3M02D | 100% | TB26 - 2 - Manuf and Delivy |  |  | P3M02L | P3M02L | 860 | M02 | 00 | DC | 2DC8490 | 200 | 200 | 400 | P |  | DEL | LND | C2 | P | M | PM16 | 1232 | E | LND |
| P3M02X1 |  | M02 Recycle Gas Compr. - FAT PLC for Line 1 |  | 2d | 2009-06-24 A | 2009-06-25 A | E3M0260 | 100% | TB26 - 2 - Manuf and Delivy |  |  | P3M02X1 | P3M02X1 | 860 | M02 | 00 | DC | 2DC8490 | 200 | 200 | 400 | P |  |  | LND | C2 | P | M | PM17 | 1232 | E | LND |
| P3M02X |  | M02 Recycle Gas Compr. - Final Inspection |  | 14d | 2009-12-10 A | 2009-12-23 A | E3M0260 FF+10d, P3M02X1, P3M02L FF-18d | 100% | TB26 - 2 - Manuf and Delivy | 1,438,824 | 1,438,824 | P3M02X | P3M02X | 860 | M02 | 00 | DC | 2DC8490 | 200 | 200 | 400 | P |  |  | LND | C2 | P | M | PM17 | 1232 | E | LND |
| P3M02M |  | M02 Recycle Gas Comp - Goods delivered FOB | milestone | 0d | 2010-01-22 A | 2010-01-22 A | P3M02L FF+10d | 100% | TB26 - 2 - Manuf and Delivy | 719,412 | 719,412 | P3M02M | P3M02M | 860 | M02 | 00 | DC | 2DC8490 | 200 | 200 | 400 | P |  |  | LND | C2 | P | M | PM18 | 1232 | E | LND |
| P3M02N |  | M02 Recycle Gas Compr. - Transport to Site - depends on prov. TSF areas |  | 56d | 2010-11-20 A | 2011-01-17 A | P3M02X, P3M02L, P3M02M | 100% | TB26 - 2 - Manuf and Delivy |  |  | P3M02N | P3M02N | 860 | M02 | 00 | DC | 2DC8490 | 200 | 200 | 400 | P |  |  | LND | C2 | P | M | PM18 | 1232 | E | LND |
| P3M02N1 |  | M02 Recycle Gas Compr. - Transp. Swiss-Tobolsk |  | 37d | 2010-11-20 A | 2010-12-28 A | P3M02M, P3M02N SS | 100% | TB26 - 2 - Manuf and Delivy |  |  | P3M02N1 | P3M02N1 | 860 | M02 | 00 | DC | 2DC8490 | 200 | 200 | 400 | P |  |  | LND | C2 | P | M | PM18 | 1232 | E | LND |
| P3M03N1 |  | M03 Offgas Compr. - Transp. Swiss-Tobolsk |  | 20d | 2010-12-01 A | 2010-12-20 A | P3M03N SS, P3M03M, P3M03A | 100% | TB26 - 2 - Manuf and Delivy |  |  | P3M03N1 | P3M03N1 | 860 | M03 | 00 | DC | 2DC8460 | 200 | 200 | 400 | P |  |  | LND | C2 | P | M | PM18 | 1232 | E | LND |
| P3M03N3 |  | M03 Offgas Compr. - Custom clearance Period |  | 18d | 2010-12-21 A | 2011-01-10 A | P3M03N1 | 100% | TB26 - 2 - Manuf and Delivy |  |  | P3M03N3 | P3M03N3 | 860 | M03 | 00 | DC | 2DC8460 | 200 | 200 | 400 | P |  |  | LND | C2 | P | M | PM18 | 1232 | E | LND |
| P3M02N3 |  | M02 Recycle Gas Compr. - Custom clearance Period |  | 19d | 2010-12-29 A | 2011-01-17 A | P3M02N1 | 100% | TB26 - 2 - Manuf and Delivy |  |  | P3M02N3 | P3M02N3 | 860 | M02 | 00 | DC | 2DC8490 | 200 | 200 | 400 | P |  |  | LND | C2 | P | M | PM18 | 1232 | E | LND |
|  | 1233 | **1233 Bleed Booster Compressor - CA12** |  |  | 2008-02-20 | 2011-06-29 |  |  |  |  |  |  |  |  |  |  |  |  |  |  |  |  |  |  |  |  |  |  |  |  |  |  |
|  | M | **M Mechanical - Rotating Equipment** |  |  | 2008-02-20 | 2011-06-29 |  |  |  |  |  |  |  |  |  |  |  |  |  |  |  |  |  |  |  |  |  |  |  |  |  |  |
| P3M04A |  | M04 GasBleedCompr. - Prepare Spec./Issue RFQ |  | 46d | 2008-02-20 A | 2008-04-25 A | F1540 SS, F1660 SS | 100% |  |  |  | P3M04A | P3M04A | 860 | M04 | 00 | DC | 2KB4360 | 200 | 200 | 400 | P | 3A | DEV | LND | C2 | P | M | PM11 | 1233 | E | LND |
| F6660 |  | M04 GasBleedCompr. - PMT approve RFQ |  | 12d | 2008-04-28 A | 2008-05-15 A | F6680 | 100% |  |  |  | F6660 | F6660 | 860 | M04 | 00 |  | 2KB4360 | 200 | 200 | 400 | P | 3A |  | PMT | C2 | P | M | PM11 | 1233 | 1 | LND |
| F6680 |  | M04 GasBleedCompr. - Issue RFQ to PMT | milestone | 0d | 2008-05-09 A | 2008-05-09 A | P3M04A FF | 100% |  |  |  | F6680 | F6680 | 860 | M04 | 00 |  | 2KB4360 | 200 | 200 | 400 | P | 3A |  | LND | C2 | P | M | PM11 | 1233 | 1 | LND |
| F6560 |  | M04 GasBleedCompr. - Vendor Bid Preparation |  | 26d | 2008-05-16 A | 2008-06-20 A | P3M04B | 100% |  |  |  | F6560 | F6560 | 860 | M04 | 00 | DC | 2KB4360 | 200 | 200 | 400 | P | 3A |  | LND | C2 | P | M | PM11 | 1233 | 1 | LND |
| P3M04B |  | M04 GasBleedCompr. - RFQ issued to bidders | milestone | 0d | 2008-05-16 A | 2008-05-16 A | P3M04A FF, F6660 FF | 100% |  | 25,300 | 25,300 | P3M04B | P3M04B | 860 | M04 | 00 | DC | 2KB4360 | 200 | 200 | 400 | P | 3A |  | LND | C2 | P | M | PM11 | 1233 | E | LND |
| F6690 |  | M04 GasBleedCompr. - Vendor Bid for INEOS Review | milestone | 0d | 2008-06-24 A | 2008-06-24 A | F6560 | 100% |  |  |  | F6690 | F6690 | 860 | M04 | 00 |  | 2KB4360 | 200 | 200 | 400 | P | 3A |  | LND | C2 | P | M | PM12 | 1233 | 1 | LND |
| P3M04C |  | M04 GasBleedCompr. - Eval./Negotiation |  | 51d | 2008-06-25 A | 2008-09-03 A | F6610 | 100% |  |  |  | P3M04C | P3M04C | 860 | M04 | 00 | DC | 2KB4360 | 200 | 200 | 400 | P | 3A |  | LND | C2 | P | M | PM12 | 1233 | E | LND |
| F6740 |  | M04 GasBleedCompr. - Bid tab Client appr./VA |  | 22d | 2008-08-05 A | 2008-09-03 A | P3M04C FF, E3M0430 | 100% |  |  |  | F6740 | F6740 | 860 | M04 | 00 |  | 2KB4360 | 200 | 200 | 400 | P | 3A |  | PMT | C2 | P | M | PM12 | 1233 | 1 | LND |
| P3M04D |  | M04 GasBleedCompr. - PO issued | milestone | 0d | 2008-09-04 A | 2008-09-04 A | F6740 FF, F2930 FF, P3M04C FF, E3M0420 FF | 100% |  | 101,200 | 101,200 | P3M04D | P3M04D | 860 | M04 | 00 | DC | 2KB4360 | 200 | 200 | 400 | P | 3A |  | LND | C2 | P | M | PM13 | 1233 | E | LND |
| P3M04L |  | M04 GasBleedCompr. - Lead Time/Fabrication |  | 928d | 2008-09-04 A | 2011-03-31 A | P3M04D | 100% | TB26 - 2 - Manuf and Delivy |  |  | P3M04L | P3M04L | 860 | M04 | 00 | DC | 2KB4360 | 200 | 200 | 400 | P |  | DEL | LND | C2 | P | M | PM16 | 1233 | E | LND |
| P3M04X |  | M04 GasBleedCompr. - Final Inspection |  | 2d | 2011-01-26 A | 2011-01-27 A | E3M0465, P3M04L FF-4d, E3M0460 FF+10d | 100% | TB26 - 2 - Manuf and Delivy | 151,800 | 151,800 | P3M04X | P3M04X | 860 | M04 | 00 | DC | 2KB4360 | 200 | 200 | 400 | P |  |  | LND | C2 | P | M | PM17 | 1233 | E | LND |
| P3M04M |  | M04 GasBleedCompr. - Goods delivered FCA/FOB | milestone | 0d | 2011-01-31 A | 2011-01-31 A | P3M04L FF, E3M0470, E3M0475 | 100% | TB26 - 2 - Manuf and Delivy | 75,900 | 75,900 | P3M04M | P3M04M | 860 | M04 | 00 | DC | 2KB4360 | 200 | 200 | 400 | P |  |  | LND | C2 | P | M | PM18 | 1233 | E | LND |
| P3M04N |  | M04 GasBleedCompr. - Transport to Site (punch points open) |  | 38d | 2011-05-23 A | 2011-06-29 A | P3M04L FS+5d, P3M04M, P3M04X | 100% | TB26 - 2 - Manuf and Delivy |  |  | P3M04N | P3M04N | 860 | M04 | 00 | DC | 2KB4360 | 200 | 200 | 400 | P |  |  | LND | C2 | P | M | PM18 | 1233 | E | LND |

Notes:
- P3M02B: Expenses: 900A 239804
- P3M02D: Expenses: 900A 959216
- P3M02X: Expenses: 900A 1438824
- P3M02M: Expenses: 900A 719412
- P3M02N: P3 Activity Log Info: per Truck (20days), / custom clearance (30days)
- P3M02N1: P3 Activity Log Info: per Truck / Train
- P3M03N1: P3 Activity Log Info: per Truck / Train
- P3M04B: Expenses: 900A 25300
- P3M04D: Expenses: 900A 101200
- P3M04L: P3 Activity Log Info: 14 / months
- P3M04X: Expenses: 900A 151800
- P3M04M: Expenses: 900A 75900
- P3M04N: P3 Activity Log Info: Rail (Responsibilty / Vendor)

| ID | WBS | Activity | Type | Duration | Start | Finish | Predecessors | Complete | Remaining | Total float | Free float | Calendar | Resources | Cost | Actual cost | UDF_SAVE ACTID | UDF_SAVE ACT ID | Department | Type of Work | Constr. Area | Pro Unit/DocCode | Inquiry/Order No | PMT-Area | PMT-Schedule Org | PMT-Discipline | PMT-Phase | PMT-Respons. | Zeigen/n. Zeigen | WBS Phase | WBS Discipline | WBS Type of Work | WBS Objects | IMS | UPT | UDF_Actictity Name (Russia) | Russia WBS Discipline (Russia) | Russia Construction Area | Russia WBS Phase | Russia WBS Objects | PMT-Doc. Type | TB26 Ressource Budget |
| --- | --- | --- | --- | --- | --- | --- | --- | --- | --- | --- | --- | --- | --- | --- | --- | --- | --- | --- | --- | --- | --- | --- | --- | --- | --- | --- | --- | --- | --- | --- | --- | --- | --- | --- | --- | --- | --- | --- | --- | --- | --- |
|  | 1710 | **???????** |  |  | 2011-02-15 | 2011-04-12 |  |  |  |  |  |  |  |  |  |  |  |  |  |  |  |  |  |  |  |  |  |  |  |  |  |  |  |  |  |  |  |  |  |  |  |
| P3M01N |  | M01 Extruder - Transport to Site |  | 57d | 2011-02-15 A | 2011-04-12 A | P3M01M, P3M01L, P3M01X, P3B100 FF | 100% |  |  |  | TB26 - 2 - Manuf and Delivy |  |  |  | P3M01N | P3M01N | 860 | M01 | 00 | DC | 2DC8480 | 200 | 200 | 400 | P | LND | C2 | P | M | PM38 | 1710 | E | LND |  |  |  |  |  |  |  |
|  | 0C | **0C Construction Milestones Disciplines** |  |  | 2010-07-22 | 2010-07-22 |  |  |  |  |  |  |  |  |  |  |  |  |  |  |  |  |  |  |  |  |  |  |  |  |  |  |  |  |  |  |  |  |  |  |  |
|  | 0000 | **0000 Generals - all CA's** |  |  | 2010-07-22 | 2010-07-22 |  |  |  |  |  |  |  |  |  |  |  |  |  |  |  |  |  |  |  |  |  |  |  |  |  |  |  |  |  |  |  |  |  |  |  |
|  | 0B | **0B General Activities** |  |  | 2010-07-22 | 2010-07-22 |  |  |  |  |  |  |  |  |  |  |  |  |  |  |  |  |  |  |  |  |  |  |  |  |  |  |  |  |  |  |  |  |  |  |  |
| P3D1010 |  | Contract Award General Cargo Contractor | milestone | 0d | 2010-07-22 A | 2010-07-22 A | P3D1000 (other project) SS | 100% |  |  |  | TB26 - 3 - Construct-normal * |  |  |  | P3D1010 | P3D1010 | 934 | D01 | 0C |  | D01 | 200 | 200 |  | C | OWN | L2 | P | 0B | X030 | 0000 | CW | LND | Начало монтажа подземных сооружений | 0 | 0C | P | 0000 |  |  |
|  | 0P | **0P Procurement Milestones Disciplines** |  |  | 2010-04-01 | 2010-06-14 |  |  |  |  |  |  |  |  |  |  |  |  |  |  |  |  |  |  |  |  |  |  |  |  |  |  |  |  |  |  |  |  |  |  |  |
|  | LUZ2 | **LUZ2 General ( )** |  |  | 2010-04-01 | 2010-06-14 |  |  |  |  |  |  |  |  |  |  |  |  |  |  |  |  |  |  |  |  |  |  |  |  |  |  |  |  |  |  |  |  |  |  |  |
|  | 0B | **0B General Activities** |  |  | 2010-04-01 | 2010-06-14 |  |  |  |  |  |  |  |  |  |  |  |  |  |  |  |  |  |  |  |  |  |  |  |  |  |  |  |  |  |  |  |  |  |  |  |
| PR10020 |  | 1st PO release AG Piping Material | milestone | 0d | 2010-04-01 A | 2010-04-01 A | P3R06AD FF, P3R06BD FF | 100% |  |  |  |  |  |  |  | PR10020 | PR10020 | G |  | 0P |  |  | 200 | 200 |  | E | LND |  | P | 0B | 0000 | LUZ2 | PI | LND |  |  |  |  |  |  |  |
| PR10010 |  | 1st PO release UG Piping Material | milestone | 0d | 2010-06-14 A | 2010-06-14 A | P3R02AD FF | 100% |  |  |  |  |  |  |  | PR10010 | PR10010 | G |  | 0P |  |  | 200 | 200 |  | E | LND |  | P | 0B | 0000 | LUZ2 | PI | LND |  |  |  |  |  |  |  |
|  | 10 | **10 CA10 - Propylene Recovery Unit Area** |  |  | 2009-12-16 | 2012-01-22 |  |  |  |  |  |  |  |  |  |  |  |  |  |  |  |  |  |  |  |  |  |  |  |  |  |  |  |  |  |  |  |  |  |  |  |
|  | LUZ2 | **LUZ2 General ( )** |  |  | 2009-12-16 | 2011-10-14 |  |  |  |  |  |  |  |  |  |  |  |  |  |  |  |  |  |  |  |  |  |  |  |  |  |  |  |  |  |  |  |  |  |  |  |
|  | U | **U Package Units** |  |  | 2009-12-16 | 2011-10-14 |  |  |  |  |  |  |  |  |  |  |  |  |  |  |  |  |  |  |  |  |  |  |  |  |  |  |  |  |  |  |  |  |  |  |  |
| P3U12D |  | PU12 Propyl.Recov.Unit - PO issued | milestone | 0d | 2009-12-16 A | 2009-12-16 A | F8390, P3U12C | 100% |  |  |  |  |  | 1,358,661.4 | 1,358,661.4 | P3U12D | P3U12D | 860 | PU12 | 10 |  | 2KB4240 | 200 | 200 | 400 | P | LND | C4 | P | U | PU93 | LUZ2 | P | IMS |  |  |  |  |  |  |  |
| P3U12L |  | PU12 Propyl.Recov.Unit - Lead Time/Fabrication |  | 583d | 2009-12-17 A | 2011-07-30 A | P3U12D | 100% |  |  |  | TB26 - 2 - Manuf and Delivy |  |  |  | P3U12L | P3U12L | 860 | PU12 | 10 |  | 2KB4240 | 200 | 200 | 400 | P | LND | C4 | P | U | PU96 | LUZ2 | E | LND |  |  |  |  |  | DEL |  |
| P3U12M |  | PU12 Propyl.Recov.Unit - Goods deliv. FOB | milestone | 0d | 2011-08-25 A | 2011-08-25 A | P3U12L FF+26d, P3U12X FF | 100% |  |  |  | TB26 - 2 - Manuf and Delivy |  | 1,018,996.05 | 1,018,996.05 | P3U12M | P3U12M | 860 | PU12 | 10 |  | 2KB4240 | 200 | 200 | 400 | P | LND | C4 | P | U | PU98 | LUZ2 | E | LND |  |  |  |  |  |  |  |
| P3U12N |  | PU12 Propyl.Recov.Unit - Transport to Site |  | 50d | 2011-08-26 A | 2011-10-14 | P3U12M, P3B100 FF |  | 44d | -102d | 0d | TB26 - 2 - Manuf and Delivy |  |  |  | P3U12N | P3U12N | 860 | PU12 | 10 |  | 2KB4240 | 200 | 200 | 400 | P | LND | C4 | P | U | PU98 | LUZ2 | E | LND |  |  |  |  |  |  |  |
|  | 1010 | **1010 Propylene Recovery Unit Area - CA10** |  |  | 2011-02-26 | 2012-01-22 |  |  |  |  |  |  |  |  |  |  |  |  |  |  |  |  |  |  |  |  |  |  |  |  |  |  |  |  |  |  |  |  |  |  |  |
|  | N | **N Structural Steel** |  |  | 2011-02-26 | 2012-01-22 |  |  |  |  |  |  |  |  |  |  |  |  |  |  |  |  |  |  |  |  |  |  |  |  |  |  |  |  |  |  |  |  |  |  |  |
| P3N02XE |  | CA10 PRU SK1001 - Vendor Procurement |  | 35d | 2011-02-26 A | 2011-04-01 A | EN27101005 FF+14d | 100% |  |  |  | TB26 - 2 - Manuf and Delivy |  |  |  | P3N02XE | P3N02XE | 860 | N02X | 10 |  | N02X | 200 | 200 | 400 | P | Chel | 0 | P | N | PN25 | 1010 | SS | LND |  |  |  |  |  | DEL |  |
| P3N02XL |  | CA10 PRU SK1001 - Vendor Fabrication |  | 40d | 2011-04-09 A | 2011-05-19 A | P3N02XE SS+20d, EN281010 SS+20d | 100% |  |  |  | TB26 - 2 - Manuf and Delivy |  |  |  | P3N02XL | P3N02XL | 860 | N02X | 10 |  | N02X | 200 | 200 | 400 | P | Chel | 0 | P | N | PN26 | 1010 | SS | LND |  |  |  |  |  | DEL |  |
| PN661010 |  | CA10 PRU SK1001 - Fabrication Gratings |  | 35d | 2011-04-21 A | 2011-05-26 A | EN651010, EN281010 SS+15d, EN681010 | 100% |  |  |  | TB26 - 2 - Manuf and Delivy |  |  |  | PN661010 | PN661010 | 860 | N02X | 10 |  | N02X | 200 | 200 |  | C | Chel |  | P | N | PN66 | 1010 | S | LND |  |  |  |  |  |  |  |
| P3N02XP |  | CA10 PRU SK1001 - Transport to Site |  | 10d | 2011-05-20 A | 2011-05-29 A | P3N02XL | 100% |  |  |  | TB26 - 2 - Manuf and Delivy | Ladders & Platforms (Delivery) [23 t] |  |  | P3N02XP | P3N02XP | 860 | N02X | 10 |  | N02X | 200 | 200 | 400 | P | Chel | 0 | P | N | PN28 | 1010 | SS | LND |  |  |  |  |  |  | 0,00 |
| PN681010 |  | CA10 PRU SK1001 - Transport Gratings to Site |  | 10d | 2011-05-27 A | 2011-06-05 A | PN661010 | 100% |  |  |  | TB26 - 2 - Manuf and Delivy |  |  |  | PN681010 | PN681010 | 860 | N02X | 10 |  | N02X | 200 | 200 |  | C | Chel |  | P | N | PN68 | 1010 | SS | LND |  |  |  |  |  |  |  |
| P3N02XN |  | CA10 PRU SK1001 - Goods arrived at Site | milestone | 0d | 2011-05-29 A | 2011-05-29 A | P3N02XP FF, IMS-P-000080 (other project) FF | 100% |  |  |  | TB26 - 2 - Manuf and Delivy |  |  |  | P3N02XN | P3N02XN | 860 | N02X | 10 |  | N02X | 200 | 200 | 400 | P | Chel | L2 | P | N | PN29 | 1010 | SS | LND | CA10 Участок PRU - Прибытие товара на площадку |  |  |  |  |  |  |
| PN691010 |  | CA10 PRU SK1001 - Gratings arrived at Site | milestone | 0d | 2011-06-05 A | 2011-06-05 A | PN681010 FF | 100% |  |  |  | TB26 - 2 - Manuf and Delivy |  |  |  | PN691010 | PN691010 | 860 | N02X | 10 |  | N02X | 200 | 200 |  | C | Chel |  | P | N | PN69 | 1010 | SS | LND |  |  |  |  |  |  |  |
| P3N02~E |  | CA18 Chiller Unit SK1801 - Vendor Procurement |  | 30d | 2011-11-03 | 2011-12-02 | EN27180110 |  |  | 508.5d | 8d | TB26 - 2 - Manuf and Delivy |  |  |  | P3N02XE | P3N02~E | 860 | N02~ | 18 |  | N02~ | 200 | 200 | 400 | P | Chel | 0 | P | N | PN25 | 1810 | SS | LND |  |  |  |  |  | DEL |  |
| P3N02~L |  | CA18 Chiller Unit SK1801 - Vendor Fabrication |  | 40d | 2011-12-01 | 2012-01-12 | P3N02~E SS+20d, EN281801 SS+20d |  |  | 500.5d | 0d | TB26 - 2 - Manuf and Delivy |  |  |  | P3N02XL | P3N02~L | 860 | N02~ | 18 |  | N02~ | 200 | 200 | 400 | P | Chel | 0 | P | N | PN26 | 1810 | SS | LND |  |  |  |  |  | DEL |  |
| P3N02~P |  | CA18 Chiller Unit SK1801 - Transport to Site |  | 10d | 2012-01-13 | 2012-01-22 | P3N02~L |  |  | 500.5d | 0d | TB26 - 2 - Manuf and Delivy |  |  |  | P3N02XP | P3N02~P | 860 | N02~ | 18 |  | N02~ | 200 | 200 | 400 | P | Chel | 0 | P | N | PN28 | 1810 | SS | LND |  |  |  |  |  |  |  |
| P3N02~N |  | CA18 Chiller Unit SK1801 - Goods arrived at Site | milestone | 0d | 2012-01-22 | 2012-01-22 | P3N02~P FF |  |  | 500.5d |  | TB26 - 2 - Manuf and Delivy |  |  |  | P3N02XN | P3N02~N | 860 | N02~ | 18 |  | N02~ | 200 | 200 | 400 | P | Chel | L2 | P | N | PN29 | 1810 | SS | LND | CA10 Участок PRU - Прибытие товара на площадку |  |  |  |  |  |  |

Notes:
- P3M01N: P3 Activity Log Info: Ship (15) / Train (30-50) / cust.clear. (30)
- P3U12D: Expenses: 900A 1358661
- P3U12M: Expenses: 900A 1018996

| ID | WBS | Activity | Type | Duration | Start | Finish | Predecessors | Complete | Total float | Free float | Calendar | Resources | Cost | Actual cost | UDF_SAVE ACTID | UDF_SAVE ACT ID | Department | Type of Work | Constr. Area | Inquiry/Order No | PMT-Area | PMT-Schedule Org | PMT-Discipline | PMT-Phase | PMT-Respons. | Zeigen/n. Zeigen | WBS Phase | WBS Discipline | WBS Type of Work | WBS Objects | IMS | UPT | PMT-Doc. Type | TB26 Ressource Budget | Pro Unit/DocCode |
| --- | --- | --- | --- | --- | --- | --- | --- | --- | --- | --- | --- | --- | --- | --- | --- | --- | --- | --- | --- | --- | --- | --- | --- | --- | --- | --- | --- | --- | --- | --- | --- | --- | --- | --- | --- |
|  | U | **U Package Units** |  |  | 2011-10-14 | 2011-10-14 |  |  |  |  |  |  |  |  |  |  |  |  |  |  |  |  |  |  |  |  |  |  |  |  |  |  |  |  |  |
| P3U12S |  | PU12 Propyl.Recov.Unit - Goods arr.at Site CA10 | milestone | 0d | 2011-10-14 | 2011-10-14 | P3U12G, IMS-P-000020 (other project), P3U12N FF |  | -102d | 0d | TB26 - 2 - Manuf and Delivy |  | 679,331 |  | P3U12S | P3U12S | 860 | PU12 | 10 | 2KB4240 | 200 | 200 | 400 | P | OWN | C4 | P | U | PU99 | 1010 | EQ | IMS |  |  |  |
|  | 11 | **11 CA11 - Offgas Compression Line 1 + 2** |  |  | 2010-10-06 | 2011-12-14 |  |  |  |  |  |  |  |  |  |  |  |  |  |  |  |  |  |  |  |  |  |  |  |  |  |  |  |  |  |
|  | 1104 | **1104 Structures inside Offgas Compr Bldg - CA11** |  |  | 2010-10-30 | 2011-03-10 |  |  |  |  |  |  |  |  |  |  |  |  |  |  |  |  |  |  |  |  |  |  |  |  |  |  |  |  |  |
|  | N | **N Structural Steel** |  |  | 2010-10-30 | 2011-03-10 |  |  |  |  |  |  |  |  |  |  |  |  |  |  |  |  |  |  |  |  |  |  |  |  |  |  |  |  |  |
| P3N02AE |  | CA11 Str.i.ComprBldg SK1105 - Vendor Procurement |  | 40d | 2010-10-30 A | 2010-12-08 A | EN27111010 | 100% |  |  | TB26 - 2 - Manuf and Delivy |  |  |  | P3N02AE | P3N02AE | 860 | N02A | 11 | N02A | 200 | 200 | 400 | P | Chel | 0 | P | N | PN25 | 1104 | SS | LND | DEL |  |  |
| P3N02AL |  | CA11 Str.i.ComprBldg SK1105 - Vendor Fabrication |  | 40d | 2011-01-20 A | 2011-02-28 A | EN281110 SS+40d, P3N02AE SS+20d | 100% |  |  | TB26 - 2 - Manuf and Delivy |  |  |  | P3N02AL | P3N02AL | 860 | N02A | 11 | N02A | 200 | 200 | 400 | P | Chel | 0 | P | N | PN26 | 1104 | SS | LND | DEL |  |  |
| P3N02AP |  | CA11 Str.i.ComprBldg SK1105 - Transport to Site |  | 10d | 2011-03-01 A | 2011-03-10 A | P3N02AL | 100% |  |  | TB26 - 2 - Manuf and Delivy | Ladders & Platforms (Delivery) [31 t] |  |  | P3N02AP | P3N02AP | 860 | N02A | 11 | N02A | 200 | 200 | 400 | P | Chel | 0 | P | N | PN28 | 1104 | SS | LND |  | 0,00 |  |
| P3N02AN |  | CA11 Str.i.ComprBldg SK1105 - Goods arrived at Site | milestone | 0d | 2011-03-10 A | 2011-03-10 A | P3N02AP FF | 100% |  |  | TB26 - 2 - Manuf and Delivy |  |  |  | P3N02AN | P3N02AN | 860 | N02A | 11 | N02A | 200 | 200 | 400 | P | Chel | L2 | P | N | PN29 | 1104 | M | LND |  |  |  |
|  | 1110 | **1110 Offgas Compressor Building - CA11** |  |  | 2011-01-10 | 2011-12-14 |  |  |  |  |  |  |  |  |  |  |  |  |  |  |  |  |  |  |  |  |  |  |  |  |  |  |  |  |  |
|  | N | **N Structural Steel** |  |  | 2011-01-29 | 2011-06-06 |  |  |  |  |  |  |  |  |  |  |  |  |  |  |  |  |  |  |  |  |  |  |  |  |  |  |  |  |  |
| PN661110 |  | CA11 ComprBldg SK1101 - Fabrication Gratings |  | 80d | 2011-01-29 A | 2011-04-18 A | EN681110 | 100% |  |  | TB26 - 2 - Manuf and Delivy |  |  |  | PN661110 | PN661110 | 860 | XNK | 11 |  | 200 | 200 |  | C | SC |  | P | N | PN66 | 1110 | SS | LND |  |  |  |
| P3N02KE |  | CA11 C.Bldg SK1101- Vendor Procurement |  | 49d | 2011-03-15 A | 2011-05-03 A | EN27111015 | 100% |  |  | TB26 - 2 - Manuf and Delivy |  |  |  | P3N02KE | P3N02KE | 860 | N02K | 11 | N02K | 200 | 200 | 400 | P | Chel | FL | P | N | PN25 | 1110 | SS | LND | DEL |  |  |
| PN681110 |  | CA11 ComprBldg SK1101 - Transport Gratings to Site |  | 10d | 2011-04-19 A | 2011-04-28 A | PN661110 | 100% |  |  | TB26 - 2 - Manuf and Delivy |  |  |  | PN681110 | PN681110 | 860 | XNK | 11 |  | 200 | 200 |  | C | SC |  | P | N | PN68 | 1110 | SS | LND |  |  |  |
| PN691110 |  | CA11 ComprBldg SK1101 - Gratings arrived at Site | milestone | 0d | 2011-04-28 A | 2011-04-28 A | PN681110 FF | 100% |  |  | TB26 - 2 - Manuf and Delivy |  |  |  | PN691110 | PN691110 | 860 | XNK | 11 |  | 200 | 200 |  | C | SC |  | P | N | PN69 | 1110 | S | LND |  |  |  |
| P3N02KL |  | CA11 C.Bldg SK1101 - Vendor Fabrication |  | 25d | 2011-05-10 A | 2011-06-03 A | P3N02KE SS+20d, EN28111005 SS+20d | 100% |  |  | TB26 - 2 - Manuf and Delivy |  |  |  | P3N02KL | P3N02KL | 860 | N02K | 11 | N02K | 200 | 200 | 400 | P | Chel | FL | P | N | PN26 | 1110 | SS | LND | DEL |  |  |
| P3N02KP |  | CA11 C.Bldg SK1101- Transport to Site |  | 3d | 2011-06-04 A | 2011-06-06 A | P3N02KL | 100% |  |  | TB26 - 2 - Manuf and Delivy | Ladders & Platforms (Delivery) [5 t]; Piperacks, Main Structures (Delivery) [126 t] |  |  | P3N02KP | P3N02KP | 860 | N02K | 11 | N02K | 200 | 200 | 400 | P | Chel | FL | P | N | PN28 | 1110 | SS | LND |  | 0,00 |  |
| P3N02KN |  | CA11 C.Bldg SK1101- Goods arrived at Site | milestone | 0d | 2011-06-06 A | 2011-06-06 A | P3N02KP FF | 100% |  |  | TB26 - 2 - Manuf and Delivy |  |  |  | P3N02KN | P3N02KN | 860 | N02K | 11 | N02K | 200 | 200 | 400 | P | Chel | FL | P | N | PN29 | 1110 | SS | LND |  |  |  |
|  | H | **H HVAC** |  |  | 2011-12-14 | 2011-12-14 |  |  |  |  |  |  |  |  |  |  |  |  |  |  |  |  |  |  |  |  |  |  |  |  |  |  |  |  |  |
| P3H01SB |  | H01 HVAC Eqt. - 1stGoods arr. at Site CA11 CompB | milestone | 0d | 2011-12-14 | 2011-12-14 | P3H01P SF+260d |  | 111d | 90.5d | TB26 - 2 - Manuf and Delivy |  |  |  | P3H01SB | P3H01SB | 860 | H01 | 11 | H01 | 000 | 200 | 400 | P | SC | L2 | P | H | PH19 | 1110 | hva_as | LND |  |  |  |
|  | B | **B Mechanical - Stationary Equipment** |  |  | 2011-03-30 | 2011-09-25 |  |  |  |  |  |  |  |  |  |  |  |  |  |  |  |  |  |  |  |  |  |  |  |  |  |  |  |  |  |
| P3A16S |  | A16 Offgas C Filters- Goods arrived at Site CA11 | milestone | 0d | 2011-03-30 A | 2011-03-30 A | P3A16N, P3A16G | 100% |  |  | TB26 - 2 - Manuf and Delivy |  | 38,200 | 38,200 | P3A16S | P3A16S | 860 | A16 | 11 | 2DC8560 | 200 | 200 | 400 | P | LND | C2 | P | B | PB88 | 1111 | E | LND |  |  | DC |
| P3A12S3 |  | A12 Overhead Cranes - Goods arrived at Site CA11 | milestone | 0d | 2011-09-25 | 2011-09-25 | P3A12N |  | 86d | 29d | TB26 - 2 - Manuf and Delivy |  |  |  | P3A12S3 | P3A12S3 | 860 | A12 | 11 | 2KB4740 | 200 | 200 | 400 | P | OWN | 0 | P | B | PB99 | 1110 | S | LND |  |  |  |
|  | M | **M Mechanical - Rotating Equipment** |  |  | 2011-01-10 | 2011-01-10 |  |  |  |  |  |  |  |  |  |  |  |  |  |  |  |  |  |  |  |  |  |  |  |  |  |  |  |  |  |
| P3M03S1 |  | M03 Offgas Compr. - Goods arrived at site CA11 | milestone | 0d | 2011-01-10 A | 2011-01-10 A | P3M03N3 FF, P3M03G, P3M03N FF, E3M0370, HPMM03 FF | 100% |  |  | TB26 - 2 - Manuf and Delivy |  | 443,552 | 443,552 | P3M03S1 | P3M03S1 | 860 | M03 | 11 | 2DC8460 | 200 | 200 | 400 | P | PMT | C2 | P | M | PM19 | 1110 | S | LND |  |  | DC |

Notes:
- P3U12S: Expenses: 900A 679331
- P3N02AN: UDF_Actictity Name (Russia): CA11 Компрессорная SK1101 - Прибытие товара на площадку
- P3H01SB: UDF_Actictity Name (Russia): H01 Оборудование ОВКВ - Прибытие 1-й партии товара на площадку, CA11 Компрессорная
- P3A16S: Expenses: 900A 38200
- P3M03S1: Expenses: 900A 443552

| ID | WBS | Activity | Type | Duration | Start | Finish | Predecessors | Complete | Total float | Free float | Calendar | Resources | Cost | Actual cost | UDF_SAVE ACTID | UDF_SAVE ACT ID | Department | Type of Work | Constr. Area | Inquiry/Order No | PMT-Area | PMT-Schedule Org | PMT-Discipline | PMT-Phase | PMT-Doc. Type | PMT-Respons. | Zeigen/n. Zeigen | WBS Phase | WBS Discipline | WBS Type of Work | WBS Objects | IMS | UPT | TB26 Ressource Budget | Pro Unit/DocCode | UDF_CONTRACT INDICATOR |
| --- | --- | --- | --- | --- | --- | --- | --- | --- | --- | --- | --- | --- | --- | --- | --- | --- | --- | --- | --- | --- | --- | --- | --- | --- | --- | --- | --- | --- | --- | --- | --- | --- | --- | --- | --- | --- |
|  | 1111 | **1111 Offgas Compressor Filter Section - CA11** |  |  | 2010-10-06 | 2011-03-02 |  |  |  |  |  |  |  |  |  |  |  |  |  |  |  |  |  |  |  |  |  |  |  |  |  |  |  |  |  |  |
|  | N | **N Structural Steel** |  |  | 2010-10-06 | 2011-03-02 |  |  |  |  |  |  |  |  |  |  |  |  |  |  |  |  |  |  |  |  |  |  |  |  |  |  |  |  |  |  |
| P3N02*E |  | CA11 OffgComprFilt SK1104 - Vendor Procurement |  | 41d | 2010-10-06 A | 2010-11-15 A | EN27111110 | 100% |  |  | TB26 - 2 - Manuf and Delivy |  |  |  | P3N02*E | P3N02*E | 860 | N02* | 11 | N02* | 200 | 200 | 400 | P | DEL | Chel | FL | P | N | PN25 | 1111 | SS | LND |  |  |  |
| P3N02*L |  | CA11 OffgComprFilt SK1104 - Vendor Fabrication |  | 59d | 2010-12-16 A | 2011-02-15 A | P3N02*E SS+45d, EN281111 FF+23d, EN281111 SS+45d | 100% |  |  | TB26 - 2 - Manuf and Delivy |  |  |  | P3N02*L | P3N02*L | 860 | N02* | 11 | N02* | 200 | 200 | 400 | P | DEL | Chel | FL | P | N | PN26 | 1111 | SS | LND |  |  |  |
| PN661111 |  | CA11 OffgComprFilt SK1104 - Fabrication Gratings |  | 57d | 2010-12-30 A | 2011-02-25 A | P3N02*L SS, EN681111, EN641111 | 100% |  |  | TB26 - 2 - Manuf and Delivy |  |  |  | PN661111 | PN661111 | 860 | N02* | 11 | N02* | 200 | 200 |  | C |  | Chel |  | P | N | PN66 | 1111 | SS | LND |  |  |  |
| P3N02*P |  | CA11 OffgComprFilt SK1104 - Transport to Site |  | 5d | 2011-02-16 A | 2011-02-20 A | P3N02*L | 100% |  |  | TB26 - 2 - Manuf and Delivy | Piperacks, Main Structures (Delivery) [37 t]; Ladders & Platforms (Delivery) [2 t] |  |  | P3N02*P | P3N02*P | 860 | N02* | 11 | N02* | 200 | 200 | 400 | P |  | Chel | FL | P | N | PN28 | 1111 | SS | LND | 0,00 |  |  |
| P3N02*N |  | CA11 OffgComprFilt SK1104 - Goods arrived at Site | milestone | 0d | 2011-02-20 A | 2011-02-20 A | P3N02*P FF | 100% |  |  | TB26 - 2 - Manuf and Delivy |  |  |  | P3N02*N | P3N02*N | 860 | N02* | 11 | N02* | 200 | 200 | 400 | P |  | Chel | FL | P | N | PN29 | 1111 | SS | LND |  |  |  |
| PN681111 |  | CA11 OffgComprFilt SK1104 - Transport Gratings to Site |  | 5d | 2011-02-26 A | 2011-03-02 A | PN661111 | 100% |  |  | TB26 - 2 - Manuf and Delivy |  |  |  | PN681111 | PN681111 | 860 | N02* | 11 | N02* | 200 | 200 |  | C |  | Chel |  | P | N | PN68 | 1111 | SS | LND |  |  |  |
| PN691111 |  | CA11 OffgComprFilt SK1104 - Gratings arrived at Site | milestone | 0d | 2011-03-02 A | 2011-03-02 A | PN681111 FF | 100% |  |  | TB26 - 2 - Manuf and Delivy |  |  |  | PN691111 | PN691111 | 860 | N02* | 11 | N02* | 200 | 200 |  | C |  | Chel |  | P | N | PN69 | 1111 | S | LND |  |  |  |
|  | B | **B Mechanical - Stationary Equipment** |  |  |  |  |  |  |  |  |  |  |  |  |  |  |  |  |  |  |  |  |  |  |  |  |  |  |  |  |  |  |  |  |  |  |
|  | 12 | **12 CA12 - Polymerization Line 1** |  |  | 2010-08-25 | 2012-02-25 |  |  |  |  |  |  |  |  |  |  |  |  |  |  |  |  |  |  |  |  |  |  |  |  |  |  |  |  |  |  |
|  | 1201 | **1201 Reactor Structure - CA12** |  |  | 2010-08-25 | 2012-02-25 |  |  |  |  |  |  |  |  |  |  |  |  |  |  |  |  |  |  |  |  |  |  |  |  |  |  |  |  |  |  |
|  | N | **N Structural Steel** |  |  | 2010-10-05 | 2011-05-06 |  |  |  |  |  |  |  |  |  |  |  |  |  |  |  |  |  |  |  |  |  |  |  |  |  |  |  |  |  |  |
| P3N02DE |  | CA12 ReactorStr SK1201 - Vendor Procurement |  | 40d | 2010-10-05 A | 2010-11-13 A | EN27120110 | 100% |  |  | TB26 - 2 - Manuf and Delivy |  |  |  | P3N02DE | P3N02DE | 860 | N02D | 12 | N02D | 200 | 200 | 400 | P | DEL | Chel | 0 | P | N | PN25 | 1201 | SS | LND |  |  |  |
| PN661201 |  | CA12 ReactorStruc - Fabrication Gratings |  | 70d | 2010-11-03 A | 2011-01-14 A | EN681201, EN641201 | 100% |  |  | TB26 - 2 - Manuf and Delivy |  |  |  | PN661201 | PN661201 | 860 | XNK | 12 |  | 200 | 200 |  | C |  |  |  | P | N | PN66 | 1201 | SS | LND |  |  |  |
| P3N02DL |  | CA12 ReactorStr SK1201 - Vendor Fabrication |  | 145d | 2010-11-29 A | 2011-04-25 A | P3N02DE SS+25d, EN281201 SS+33d | 100% |  |  | TB26 - 2 - Manuf and Delivy |  |  |  | P3N02DL | P3N02DL | 860 | N02D | 12 | N02D | 200 | 200 | 400 | P | DEL | Chel | 0 | P | N | PN26 | 1201 | SS | LND |  |  |  |
| PN681201 |  | CA12 ReactorStruc - Transport Gratings to Site |  | 10d | 2011-01-15 A | 2011-01-24 A | PN661201 | 100% |  |  | TB26 - 2 - Manuf and Delivy |  |  |  | PN681201 | PN681201 | 860 | XNK | 12 |  | 200 | 200 |  | C |  |  |  | P | N | PN68 | 1201 | SS | LND |  |  |  |
| PN691201 |  | CA12 ReactorStruc - Gratings arrived at Site | milestone | 0d | 2011-01-24 A | 2011-01-24 A | PN681201 FF | 100% |  |  | TB26 - 2 - Manuf and Delivy |  |  |  | PN691201 | PN691201 | 860 | XNK | 12 |  | 200 | 200 |  | C |  |  |  | P | N | PN69 | 1201 | S | LND |  |  |  |
| P3N02DP |  | CA12 ReactorStr SK1201 - Transport to Site |  | 86d | 2011-02-09 A | 2011-05-06 A | P3N02DL FF+10d | 100% |  |  | TB26 - 2 - Manuf and Delivy | Piperacks, Main Structures (Delivery) [702 t]; Ladders & Platforms (Delivery) [31 t] |  |  | P3N02DP | P3N02DP | 860 | N02D | 12 | N02D | 200 | 200 | 400 | P |  | Chel | 0 | P | N | PN28 | 1201 | SS | LND | 0,00 |  |  |
| P3N02DN |  | CA12 ReactorStr SK1201 - Goods arrived at Site 1st LOT | milestone | 0d | 2011-02-18 A | 2011-02-18 A | P3N02DP SF+10d | 100% |  |  | TB26 - 2 - Manuf and Delivy |  |  |  | P3N02DN | P3N02DN | 860 | N02D | 12 | N02D | 200 | 200 | 400 | P |  | Chel | L2 | P | N | PN29 | 1201 | M | LND |  |  |  |
|  | U | **U Package Units** |  |  | 2011-08-30 | 2011-08-30 |  |  |  |  |  |  |  |  |  |  |  |  |  |  |  |  |  |  |  |  |  |  |  |  |  |  |  |  |  |  |
| P3U15S1 |  | PU15 Reactor Seal Oil P.- Goods arr.at Site CA12 | milestone | 0d | 2011-08-30 A | 2011-08-30 A | HPU15 FF, IMS-P-000070 (other project) FF, P3U15N FF, P3U15G | 100% |  |  | TB26 - 2 - Manuf and Delivy |  | 76,700 | 76,700 | P3U15S1 | P3U15S1 | 860 | PU15 | 12 | 2DC8910 | 200 | 200 | 400 | P |  | OWN | 0 | P | U | PU99 | 1201 | S | LND |  |  |  |
|  | B | **B Mechanical - Stationary Equipment** |  |  | 2010-08-25 | 2011-10-08 |  |  |  |  |  |  |  |  |  |  |  |  |  |  |  |  |  |  |  |  |  |  |  |  |  |  |  |  |  |  |
| P3A04S1 |  | A04 R Overhead Sep. - Goods arrived at site CA12 | milestone | 0d | 2010-08-25 A | 2010-08-25 A | P3A04G, P3A04N5 FF, P3A04N FF | 100% |  |  | TB26 - 2 - Manuf and Delivy |  | 64,369 | 64,369 | P3A04S1 | P3A04S1 | 860 | A04 | 12 | 2DC8500 | 200 | 200 | 400 | P |  | OWN | C2 | P | B | PB19 | 1201 | S | LND |  | DC |  |
| P3ALL1S1 |  | ALL1 React w Agitat - Goods arrived at site CA12 | milestone | 0d | 2010-08-28 A | 2010-08-28 A | X0300094 (other project) SF, P3ALL1N FF, P3ALL1G, P3ALL1N5 FF, HPBALL1 FF | 100% |  |  | TB26 - 2 - Manuf and Delivy |  | 514,850 | 514,850 | P3ALL1S1 | P3ALL1S1 | 860 | ALL1 | 12 | 2DC8440 | 200 | 200 | 400 | P |  | OWN | C2 | P | B | PB39 | 1201 | S | LND |  | DC |  |
| P3A05S1 |  | A05 Offgas Cycl & R - Goods arrived at site CA12 | milestone | 0d | 2010-10-30 A | 2010-10-30 A | E3A0570, P3A05N FF, P3A05G | 100% |  |  | TB26 - 2 - Manuf and Delivy |  | 35,824 | 35,824 | P3A05S1 | P3A05S1 | 860 | A05 | 12 | 2DC8590 | 200 | 200 | 400 | P |  | OWN | C2 | P | B | PB19 | 1201 | S | LND |  | DC |  |
| P3A04AS1 |  | A04A R Overhead Cond- Goods arrived at site CA12 | milestone | 0d | 2010-12-20 A | 2010-12-20 A | P3A04AG, P3A04AN | 100% |  |  | TB26 - 2 - Manuf and Delivy |  |  |  | P3A04AS1 | P3A04AS1 | 860 | A04A | 12 | 2DC9110 | 200 | 200 | 400 | P |  | OWN | C2 | P | B | PB19 | 1201 | S | LND |  | DC |  |
| P3A07S1 |  | A07 R Fines Eductor - Goods arrived at site CA12 | milestone | 0d | 2011-01-05 A | 2011-01-05 A | P3A07N FF, P3A07G | 100% |  |  | TB26 - 2 - Manuf and Delivy |  | 14,260 | 14,260 | P3A07S1 | P3A07S1 | 860 | A07 | 12 | 2DC8640 | 200 | 200 | 400 | P |  | OWN | C2 | P | B | PB99 | 1201 | S | LND |  | DC |  |
| P3A12S4 |  | A12 Overhead Cranes - Goods arrived at Site CA12 | milestone | 0d | 2011-09-25 | 2011-09-25 | P3A12N |  | -35.75d | 1d | TB26 - 2 - Manuf and Delivy |  |  |  | P3A12S4 | P3A12S4 | 860 | A12 | 12 | 2KB4740 | 200 | 200 | 400 | P |  | OWN | 0 | P | B | PB99 | 1201 | S | LND |  |  |  |
| P3A01S3 |  | A01 Drums/Small V. - Goods arrived at Site CA12 | milestone | 0d | 2011-10-08 | 2011-10-08 | P3A01N FF |  | -24d | 1d | TB26 - 2 - Manuf and Delivy |  |  |  | P3A01S3 | P3A01S3 | 860 | A01 | 12 | 2DD8530 | 200 | 200 | 400 | P |  | OWN | 0 | P | B | PB19 | 1201 | S | LND |  |  |  |
| P3A02CS1 |  | A02C Instrument Air Vessels - Goods arrived at Site CA12 | milestone | 0d | 2011-10-08 | 2011-10-08 | P3A02CG, P3A02CN FF, P3A02CN3 FF |  | -82d | 0d | TB26 - 2 - Manuf and Delivy |  | 12,400 |  | P3A02CS1 | P3A02CS1 | 860 | A02C | 12 | 2DD8530 | 200 | 200 | 400 | P |  | OWN | 0 | P | B | PB19 | 1201 | E | LND |  |  |  |
| P3A02CS2 |  | A02C Instrument Air Vessels - Goods arrived at Site CA11 | milestone | 0d | 2011-10-08 | 2011-10-08 | P3A02CG, P3A02CN FF |  | 79.5d | 226d | TB26 - 2 - Manuf and Delivy |  |  |  | P3A02CS2 | P3A02CS2 | 860 | A02C | 12 | 2DD8530 | 200 | 200 | 400 | P |  | OWN | 0 | P | B | PB19 | 1201 | E | LND |  |  | UDF_G1 |
| P3A06S1 |  | A06 Start-Up Heater/Condenser- Goods arrived at Site CA12 | milestone | 0d | 2011-10-08 | 2011-10-08 | P3A06G, P3A06N FF, P3A06N3 FF, HPBA06 FF |  | -86d | 0d | TB26 - 2 - Manuf and Delivy |  | 18,640 |  | P3A06S1 | P3A06S1 | 860 | A06 | 12 | 2DD8530 | 200 | 200 | 400 | P |  | OWN | 0 | P | B | PB29 | 1201 | S | LND |  |  |  |

Notes:
- P3N02DN: UDF_Actictity Name (Russia): CA12 Конструкция реактора SK1201 - Прибытие товара на площадку
- P3U15S1: Expenses: 900A 76700
- P3A04S1: Expenses: 900A 64369
- P3ALL1S1: Expenses: 900A 514850
- P3A05S1: Expenses: 900A 35824
- P3A04AS1: P3 Activity Log Info: Delivery DDU / Tobolsk
- P3A07S1: Expenses: 900A 14260
- P3A02CS1: Expenses: 900A 12400
- P3A06S1: Expenses: 900A 18640

| ID | WBS | Activity | Type | Duration | Start | Finish | Predecessors | Complete | Total float | Free float | Calendar | Resources | Cost | Actual cost | UDF_SAVE ACTID | UDF_SAVE ACT ID | Department | Type of Work | Constr. Area | Pro Unit/DocCode | Inquiry/Order No | PMT-Area | PMT-Schedule Org | PMT-Discipline | PMT-Phase | PMT-Respons. | Zeigen/n. Zeigen | WBS Phase | WBS Discipline | WBS Type of Work | WBS Objects | IMS | UPT | PMT-Doc. Type | TB26 Ressource Budget | UDF_Actictity Name (Russia) |
| --- | --- | --- | --- | --- | --- | --- | --- | --- | --- | --- | --- | --- | --- | --- | --- | --- | --- | --- | --- | --- | --- | --- | --- | --- | --- | --- | --- | --- | --- | --- | --- | --- | --- | --- | --- | --- |
|  | M | **M Mechanical - Rotating Equipment** |  |  | 2011-01-26 | 2011-03-31 |  |  |  |  |  |  |  |  |  |  |  |  |  |  |  |  |  |  |  |  |  |  |  |  |  |  |  |  |  |  |
| P3M05S1 |  | M05 R. Quench Pumps - Goods arrived at site CA12 | milestone | 0d | 2011-01-26 A | 2011-01-26 A | P3M05N FF, HPMM05 FF, P3M05G | 100% |  |  | TB26 - 2 - Manuf and Delivy |  | 116,179 | 116,179 | P3M05S1 | P3M05S1 | 860 | M05 | 12 | DC | 2PA6550 | 200 | 200 | 400 | P | OWN | C2 | P | M | PM29 | 1201 | S | LND |  |  |  |
| P3M06S1 |  | M06 R. Tepid Pumps - Goods arrived at site CA12 | milestone | 0d | 2011-01-26 A | 2011-01-26 A | P3M06N FF, P3M06G, HPMM06 FF | 100% |  |  | TB26 - 2 - Manuf and Delivy |  | 18,898 | 18,898 | P3M06S1 | P3M06S1 | 860 | M06 | 12 | DC | 2PA6540 | 200 | 200 | 400 | P | OWN | C2 | P | M | PM29 | 1201 | S | LND |  |  |  |
| P3M11S1 |  | M11 RA Gear Unit - Goods arrived at site CA12 | milestone | 0d | 2011-03-31 A | 2011-03-31 A | P3M11G, E3M1170, HPEE04 FF, P3M11N FF | 100% |  |  | TB26 - 2 - Manuf and Delivy |  | 114,090 | 114,090 | P3M11S1 | P3M11S1 | 860 | M11 | 12 | DC | 2KB4290 | 200 | 200 | 400 | P | OWN | C2 | P | M | PM99 | 1201 | S | LND |  |  |  |
|  | J | **J Instrumentation** |  |  | 2012-02-25 | 2012-02-25 |  |  |  |  |  |  |  |  |  |  |  |  |  |  |  |  |  |  |  |  |  |  |  |  |  |  |  |  |  |  |
| P3J03S1 |  | J03 Nuclear L. Meas.- Goods arrived at Site CA12 | milestone | 0d | 2012-02-25 | 2012-02-25 | P3J03G, HPJJ03 FF, P3J03N FF |  | 34d | 85d | TB26 - 2 - Manuf and Delivy |  | 56,167 |  | P3J03S1 | P3J03S1 | 860 | J03 | 12 |  | 2JD7540 | 200 | 200 | 400 | P | OWN | 0 | P | J | PJ39 | 1201 | IT | LND |  |  |  |
|  | 1204 | **1204 Connection Structure Reactor to Teal Bldg - CA12** |  |  | 2010-08-27 | 2011-02-25 |  |  |  |  |  |  |  |  |  |  |  |  |  |  |  |  |  |  |  |  |  |  |  |  |  |  |  |  |  |  |
|  | N | **N Structural Steel** |  |  | 2010-08-27 | 2011-02-25 |  |  |  |  |  |  |  |  |  |  |  |  |  |  |  |  |  |  |  |  |  |  |  |  |  |  |  |  |  |  |
| PN661204 |  | CA12 TealStr SK1202/4 - Fabrication Gratings |  | 80d | 2010-08-27 A | 2010-11-14 A | EN641204 FF, EN681204 | 100% |  |  | TB26 - 2 - Manuf and Delivy |  |  |  | PN661204 | PN661204 | 860 | XNK | 12 |  |  | 200 | 200 |  | C |  |  | P | N | PN66 | 1204 | SS | LND |  |  |  |
| P3N02EE |  | CA12 TealStr SK1204 - Vendor Procurement |  | 40d | 2010-10-02 A | 2010-11-10 A | EN27120410 | 100% |  |  | TB26 - 2 - Manuf and Delivy |  |  |  | P3N02EE | P3N02EE | 860 | N02E | 12 |  | N02E | 200 | 200 | 400 | P | Chel | 0 | P | N | PN25 | 1204 | SS | LND | DEL |  |  |
| PN681204 |  | CA12 TealStr SK1202/4-Transport Gratings to Site |  | 10d | 2010-11-15 A | 2010-11-24 A | PN661204 | 100% |  |  | TB26 - 2 - Manuf and Delivy |  |  |  | PN681204 | PN681204 | 860 | XNK | 12 |  |  | 200 | 200 |  | C |  |  | P | N | PN68 | 1204 | SS | LND |  |  |  |
| PN691204 |  | CA12 TealStr SK1202/4 - Gratings arrived at Site | milestone | 0d | 2010-11-24 A | 2010-11-24 A | PN681204 FF | 100% |  |  | TB26 - 2 - Manuf and Delivy |  |  |  | PN691204 | PN691204 | 860 | XNK | 12 |  |  | 200 | 200 |  | C |  |  | P | N | PN69 | 1204 | S | LND |  |  |  |
| P3N02EL |  | CA12 TealStr SK1204 - Vendor Fabrication |  | 55d | 2010-12-20 A | 2011-02-15 A | EN281204 SS+35d, P3N02EE SS+20d | 100% |  |  | TB26 - 2 - Manuf and Delivy |  |  |  | P3N02EL | P3N02EL | 860 | N02E | 12 |  | N02E | 200 | 200 | 400 | P | Chel | 0 | P | N | PN26 | 1204 | SS | LND | DEL |  |  |
| P3N02EP |  | CA12 TealStr SK1204 - Transport to Site |  | 10d | 2011-02-16 A | 2011-02-25 A | P3N02EL | 100% |  |  | TB26 - 2 - Manuf and Delivy | Piperacks, Main Structures (Delivery) [60 t]; Ladders & Platforms (Delivery) [1 t] |  |  | P3N02EP | P3N02EP | 860 | N02E | 12 |  | N02E | 200 | 200 | 400 | P | Chel | 0 | P | N | PN28 | 1204 | SS | LND |  | 0,00 |  |
| P3N02EN |  | CA12 TealStr SK1204 - Goods arrived at Site | milestone | 0d | 2011-02-25 A | 2011-02-25 A | P3N02EP FF | 100% |  |  | TB26 - 2 - Manuf and Delivy |  |  |  | P3N02EN | P3N02EN | 860 | N02E | 12 |  | N02E | 200 | 200 | 400 | P | Chel | L2 | P | N | PN29 | 1204 | M | LND |  |  | CA12 Здание ТЭА SK1202/4 - Прибытие товара на площадку |
|  | 1205 | **1205 Agitator Removable Unit - CA12** |  |  | 2010-11-01 | 2011-07-14 |  |  |  |  |  |  |  |  |  |  |  |  |  |  |  |  |  |  |  |  |  |  |  |  |  |  |  |  |  |  |
|  | N | **N Structural Steel** |  |  | 2010-11-01 | 2011-02-20 |  |  |  |  |  |  |  |  |  |  |  |  |  |  |  |  |  |  |  |  |  |  |  |  |  |  |  |  |  |  |
| P3N02FE |  | CA12 Agitator SK1205 - Vendor Procurement |  | 30d | 2010-11-01 A | 2010-11-30 A | EN27120510 | 100% |  |  | TB26 - 2 - Manuf and Delivy |  |  |  | P3N02FE | P3N02FE | 860 | N02F | 12 |  | N02F | 200 | 200 | 400 | P | Chel | 0 | P | N | PN25 | 1205 | SS | LND | DEL |  |  |
| P3N02FL |  | CA12 Agitator SK1205 - Vendor Fabrication |  | 57d | 2010-12-13 A | 2011-02-10 A | EN281205 SS+21d, P3N02FE SS+15d | 100% |  |  | TB26 - 2 - Manuf and Delivy |  |  |  | P3N02FL | P3N02FL | 860 | N02F | 12 |  | N02F | 200 | 200 | 400 | P | Chel | 0 | P | N | PN26 | 1205 | SS | LND | DEL |  |  |
| P661205 |  | CA12 Agitator SK1205 - Fabrication Gratings |  | 49d | 2010-12-21 A | 2011-02-10 A | EN641205 FF, EN681205 | 100% |  |  | TB26 - 2 - Manuf and Delivy |  |  |  | P661205 | P661205 | 860 | N02F | 12 |  | N02F | 200 | 200 |  | C |  |  | P | N | PN66 | 1205 | SS | LND |  |  |  |
| P3N02FP |  | CA12 Agitator SK1205 - Transport to Site |  | 10d | 2011-02-11 A | 2011-02-20 A | P3N02FL | 100% |  |  | TB26 - 2 - Manuf and Delivy | Piperacks, Main Structures (Delivery) [115 t]; Ladders & Platforms (Delivery) [4 t] |  |  | P3N02FP | P3N02FP | 860 | N02F | 12 |  | N02F | 200 | 200 | 400 | P | Chel | 0 | P | N | PN28 | 1205 | SS | LND |  | 0,00 |  |
| P681205 |  | CA12 Agitator SK1205 - Transport Gratings toSite |  | 10d | 2011-02-11 A | 2011-02-20 A | P661205 | 100% |  |  | TB26 - 2 - Manuf and Delivy |  |  |  | P681205 | P681205 | 860 | N02F | 12 |  | N02F | 200 | 200 |  | C |  |  | P | N | PN68 | 1205 | SS | LND |  |  |  |
| P3N02FN |  | CA12 Agitator SK1205 - Goods arrived at Site | milestone | 0d | 2011-02-20 A | 2011-02-20 A | P3N02FP FF | 100% |  |  | TB26 - 2 - Manuf and Delivy |  |  |  | P3N02FN | P3N02FN | 860 | N02F | 12 |  | N02F | 200 | 200 | 400 | P | Chel | L2 | P | N | PN29 | 1205 | M | LND |  |  | CA12 Мешалка SK1205 - Прибытие товара на площадку |
| P691205 |  | CA12 Agitator SK1205 - Gratings arrived at Site | milestone | 0d | 2011-02-20 A | 2011-02-20 A | P681205 FF | 100% |  |  | TB26 - 2 - Manuf and Delivy |  |  |  | P691205 | P691205 | 860 | N02F | 12 |  | N02F | 200 | 200 |  | C |  |  | P | N | PN69 | 1205 | S | LND |  |  |  |

Notes:
- P3M05S1: Expenses: 900A 116179
- P3M06S1: Expenses: 900A 18898
- P3M11S1: Expenses: 900A 114090
- P3J03S1: P3 Activity Log Info: as late / as possible to install just in / time / Expenses: 900A 56167

| ID | WBS | Activity | Type | Duration | Start | Finish | Predecessors | Complete | Total float | Free float | Calendar | Resources | Cost | Actual cost | UDF_SAVE ACTID | UDF_SAVE ACT ID | Department | Type of Work | Constr. Area | Inquiry/Order No | PMT-Area | PMT-Schedule Org | PMT-Discipline | PMT-Phase | PMT-Respons. | Zeigen/n. Zeigen | WBS Phase | WBS Discipline | WBS Type of Work | WBS Objects | IMS | UPT | PMT-Doc. Type | TB26 Ressource Budget |
| --- | --- | --- | --- | --- | --- | --- | --- | --- | --- | --- | --- | --- | --- | --- | --- | --- | --- | --- | --- | --- | --- | --- | --- | --- | --- | --- | --- | --- | --- | --- | --- | --- | --- | --- |
|  | J | **J Instrumentation** |  |  | 2011-07-14 | 2011-07-14 |  |  |  |  |  |  |  |  |  |  |  |  |  |  |  |  |  |  |  |  |  |  |  |  |  |  |  |  |
| P3J07S1 |  | J07 Analyser System - Goods arrived at Site CA12 | milestone | 0d | 2011-07-14 A | 2011-07-14 A | P3JU7G, IMS-P-000170 (other project) FF, HPJJ07 FF, P3J07N FF | 100% |  |  | TB26 - 2 - Manuf and Delivy |  | 287,000 | 287,000 | P3J07S1 | P3J07S1 | 860 | J07 | 12 | 2JD7560 | 200 | 200 | 400 | P | OWN | 0 | P | J | PJ39 | 1205 | IT | LND |  |  |
|  | 1221 | **1221 Catalyst Building Line 1 - CA12** |  |  | 2010-11-30 | 2011-12-14 |  |  |  |  |  |  |  |  |  |  |  |  |  |  |  |  |  |  |  |  |  |  |  |  |  |  |  |  |
|  | N | **N Structural Steel** |  |  | 2011-03-08 | 2011-05-16 |  |  |  |  |  |  |  |  |  |  |  |  |  |  |  |  |  |  |  |  |  |  |  |  |  |  |  |  |
| P3N02RE |  | CA12 Catalyst Bldg SK1206 - Vendor Procurement |  | 25d | 2011-03-08 A | 2011-04-01 A | EN271221 | 100% |  |  | TB26 - 2 - Manuf and Delivy |  |  |  | P3N02RE | P3N02RE | 860 | N02R | 12 | N02R | 200 | 200 | 400 | P | Chel | 0 | P | N | PN25 | 1221 | SS | LND | DEL |  |
| P3N02RL |  | CA12 Catalyst Bldg SK1206 - Vendor Fabrication |  | 44d | 2011-03-28 A | 2011-05-11 A | EN281221 SS+5d, P3N02RE SS+10d | 100% |  |  | TB26 - 2 - Manuf and Delivy |  |  |  | P3N02RL | P3N02RL | 860 | N02R | 12 | N02R | 200 | 200 | 400 | P | Chel | 0 | P | N | PN26 | 1221 | SS | LND | DEL |  |
| P3N02RP |  | CA12 Catalyst Bldg SK1206 - Transport to Site |  | 5d | 2011-05-12 A | 2011-05-16 A | P3N02RL | 100% |  |  | TB26 - 2 - Manuf and Delivy | Piperacks, Main Structures (Delivery) [40 t]; Ladders & Platforms (Delivery) [3 t] |  |  | P3N02RP | P3N02RP | 860 | N02R | 12 | N02R | 200 | 200 | 400 | P | Chel | 0 | P | N | PN28 | 1221 | SS | LND |  | 0,00 |
| P3N02RN |  | CA12 Catalyst Bldg SK1206 - Goods arrived at Site | milestone | 0d | 2011-05-16 A | 2011-05-16 A | P3N02RP FF | 100% |  |  | TB26 - 2 - Manuf and Delivy |  |  |  | P3N02RN | P3N02RN | 860 | N02R | 12 | N02R | 200 | 200 | 400 | P | Chel | L2 | P | N | PN29 | 1221 | M | LND |  |  |
|  | H | **H HVAC** |  |  | 2011-12-14 | 2011-12-14 |  |  |  |  |  |  |  |  |  |  |  |  |  |  |  |  |  |  |  |  |  |  |  |  |  |  |  |  |
| P3H01SD |  | H01 HVAC Eqt. - 1stGoods arr. at Site CA12 CatB | milestone | 0d | 2011-12-14 | 2011-12-14 | P3H01P SF+260d |  | 85d | 50d | TB26 - 2 - Manuf and Delivy |  |  |  | P3H01SD | P3H01SD | 860 | H01 | 12 | H01 | 000 | 200 | 400 | P | SC | L2 | P | H | PH19 | 1221 | hva_as | LND |  |  |
|  | B | **B Mechanical - Stationary Equipment** |  |  | 2010-11-30 | 2011-10-08 |  |  |  |  |  |  |  |  |  |  |  |  |  |  |  |  |  |  |  |  |  |  |  |  |  |  |  |  |
| P3A13S1A |  | A13 Scales - Goods arr. at Site CA12 (MI-21104) | milestone | 0d | 2010-11-30 A | 2010-11-30 A | P3A13N FF, P3A13G, HPBA13 FF | 100% |  |  | TB26 - 2 - Manuf and Delivy |  | 23,722 | 23,722 | P3A13S1A | P3A13S1A | 860 | A13 | 12 | 2DC9060 | 200 | 200 | 400 | P | OWN | 0 | P | B | PB99 | 1221 | S | LND |  |  |
| P3A03S1 |  | A03 Cat Drum Roller - Goods arrived at Site CA12 | milestone | 0d | 2011-01-05 A | 2011-01-05 A | HPBA03 FF, P3A03N FF, P3A03G | 100% |  |  | TB26 - 2 - Manuf and Delivy |  | 6,730 | 6,730 | P3A03S1 | P3A03S1 | 860 | A03 | 12 | 2DC9630 | 200 | 200 | 400 | P | LND | 0 | P | B | PB99 | 1221 | S | LND |  |  |
| P3A06AS2 |  | A06A Electrical Heater - Goods arr. at Site CA12 | milestone | 0d | 2011-06-10 A | 2011-06-10 A | P3A06AN FF, P3A06AG | 100% |  |  | TB26 - 2 - Manuf and Delivy |  | 7,522 | 7,522 | P3A06AS2 | P3A06AS2 | 860 | A06A | 12 | 2DC9080 | 200 | 200 | 400 | P | OWN | 0 | P | B | PB29 | 1221 | S | LND |  |  |
| P3A01S1 |  | A01 Drums/Small V. - Goods arrived at Site CA12 | milestone | 0d | 2011-10-08 | 2011-10-08 | HPBA01 FF, P3A01G, P3A01N FF, P3A01N3 FF |  | 5d | 79d | TB26 - 2 - Manuf and Delivy |  | 41,016 |  | P3A01S1 | P3A01S1 | 860 | A01 | 12 | 2DD8530 | 200 | 200 | 400 | P | OWN | 0 | P | B | PB19 | 1221 | S | LND |  |  |
| P3A17S |  | A17 Teal S. C. Inte - Goods arrived at Site CA12 | milestone | 0d | 2011-10-08 | 2011-10-08 | P3A17N FF, P3A17N3 FF, HPBA17 FF |  | 603.5d |  | TB26 - 2 - Manuf and Delivy |  |  |  | P3A17S | P3A17S | 860 | A17 | 12 | 2DD8530 | 200 | 200 | 400 | P | OWN | 0 | P | B | PB19 | 1201 | S | LND |  |  |
|  | M | **M Mechanical - Rotating Equipment** |  |  | 2011-03-31 | 2011-06-24 |  |  |  |  |  |  |  |  |  |  |  |  |  |  |  |  |  |  |  |  |  |  |  |  |  |  |  |  |
| P3M08S1A |  | M08 Donor Pump - Good arr. at Site CA12 P-21103 | milestone | 0d | 2011-03-31 A | 2011-03-31 A | P3M08G, HPMM08 FF, E3M0870 FF, P3M08N FF | 100% |  |  | TB26 - 2 - Manuf and Delivy |  | 10,295 | 10,295 | P3M08S1A | P3M08S1A | 860 | M08 | 12 | 2PA6690 | 200 | 200 | 400 | P | OWN | 0 | P | M | PM29 | 1221 | S | LND |  |  |
| P3M10S1 |  | M10 Cat. Waste Pumps- Goods arrived at Site CA12 | milestone | 0d | 2011-03-31 A | 2011-03-31 A | HPMM10 FF, P3M10N FF, E3M1070 FF, P3M10G | 100% |  |  | TB26 - 2 - Manuf and Delivy |  | 5,410 | 5,410 | P3M10S1 | P3M10S1 | 860 | M10 | 12 | 2PA6690 | 200 | 200 | 400 | P | OWN | 0 | P | M | PM29 | 1221 | S | LND |  |  |
| P3M09S1 |  | M09 Unloading Pumps - Goods arrived at Site CA12 | milestone | 0d | 2011-06-01 A | 2011-06-01 A | E3M0950 FF, E3M0960 FF, P3M09N FF, P3M09G, HPMM09 FF, E3M0940 FF | 100% |  |  | TB26 - 2 - Manuf and Delivy |  | 3,000 | 3,000 | P3M09S1 | P3M09S1 | 860 | M09 | 12 | 2PA6680 | 200 | 200 | 400 | P | OWN | 0 | P | M | PM29 | 1221 | S | LND |  |  |
| P3M07S1 |  | M07 Cat Feed Pumps - Goods arrived at Site CA12 | milestone | 0d | 2011-06-24 A | 2011-06-24 A | P3M07N FF, HPMM07 FF, E3M0770 FF, P3M07G | 100% |  |  | TB26 - 2 - Manuf and Delivy |  | 17,475 | 17,475 | P3M07S1 | P3M07S1 | 860 | M07 | 12 | 2PA6670 | 200 | 200 | 400 | P | OWN | 0 | P | M | PM29 | 1221 | S | LND |  |  |
|  | 1222 | **1222 Teal Building Line 1 - CA12** |  |  | 2010-11-30 | 2011-11-24 |  |  |  |  |  |  |  |  |  |  |  |  |  |  |  |  |  |  |  |  |  |  |  |  |  |  |  |  |
|  | N | **N Structural Steel** |  |  | 2011-03-08 | 2011-04-11 |  |  |  |  |  |  |  |  |  |  |  |  |  |  |  |  |  |  |  |  |  |  |  |  |  |  |  |  |
| P3N02PE |  | CA12 Teal Bldg SK1202 - Vendor Procurement |  | 20d | 2011-03-08 A | 2011-03-27 A | EN271222 | 100% |  |  | TB26 - 2 - Manuf and Delivy |  |  |  | P3N02PE | P3N02PE | 860 | N02P | 12 | N02P | 200 | 200 | 400 | P | Chel | 0 | P | N | PN25 | 1222 | SS | LND | DEL |  |
| P3N02PL |  | CA12 Teal Bldg SK1202 - Vendor Fabrication |  | 15d | 2011-03-23 A | 2011-04-06 A | P3N02PE FF+10d, EN281222 SS+10d, P3N02PE SS+10d | 100% |  |  | TB26 - 2 - Manuf and Delivy |  |  |  | P3N02PL | P3N02PL | 860 | N02P | 12 | N02P | 200 | 200 | 400 | P | Chel | 0 | P | N | PN26 | 1222 | SS | LND | DEL |  |
| P3N02PP |  | CA12 Teal Bldg SK1202 - Transport to Site |  | 5d | 2011-04-07 A | 2011-04-11 A | P3N02PL | 100% |  |  | TB26 - 2 - Manuf and Delivy | Piperacks, Main Structures (Delivery) [5 t] |  |  | P3N02PP | P3N02PP | 860 | N02P | 12 | N02P | 200 | 200 | 400 | P | Chel | 0 | P | N | PN28 | 1222 | SS | LND |  | 0,00 |
| P3N02PN |  | CA12 Teal Bldg SK1202 - Goods arrived at Site | milestone | 0d | 2011-04-11 A | 2011-04-11 A | P3N02PP FF | 100% |  |  | TB26 - 2 - Manuf and Delivy |  |  |  | P3N02PN | P3N02PN | 860 | N02P | 12 | N02P | 200 | 200 | 400 | P | Chel | L2 | P | N | PN29 | 1222 | M | LND |  |  |

Notes:
- P3J07S1: Expenses: 900A 287000
- P3N02RN: UDF_Actictity Name (Russia): CA12 Мешалка SK1205 - Прибытие товара на площадку
- P3H01SD: UDF_Actictity Name (Russia): H01 Оборудование ОВКВ - Прибытие 1-й партии товара на площадку, CA12 Здание катализатора
- P3A13S1A: Expenses: 900A 23722
- P3A03S1: Expenses: 900A 6730
- P3A06AS2: Expenses: 900A 7522
- P3A01S1: Expenses: 900A 41016
- P3M08S1A: Expenses: 900A 10295
- P3M10S1: Expenses: 900A 5410
- P3M09S1: Expenses: 900A 3000
- P3M07S1: Expenses: 900A 17475
- P3N02PN: UDF_Actictity Name (Russia): CA12 Мешалка SK1205 - Прибытие товара на площадку

| ID | WBS | Activity | Type | Duration | Start | Finish | Predecessors | Complete | Total float | Free float | Calendar | Resources | Cost | Actual cost | UDF_SAVE ACTID | UDF_SAVE ACT ID | Department | Type of Work | Constr. Area | Inquiry/Order No | PMT-Area | PMT-Schedule Org | PMT-Discipline | PMT-Phase | PMT-Respons. | Zeigen/n. Zeigen | WBS Phase | WBS Discipline | WBS Type of Work | WBS Objects | IMS | UPT | Pro Unit/DocCode | PMT-Doc. Type | TB26 Ressource Budget |
| --- | --- | --- | --- | --- | --- | --- | --- | --- | --- | --- | --- | --- | --- | --- | --- | --- | --- | --- | --- | --- | --- | --- | --- | --- | --- | --- | --- | --- | --- | --- | --- | --- | --- | --- | --- |
|  | H | **H HVAC** |  |  | 2011-11-24 | 2011-11-24 |  |  |  |  |  |  |  |  |  |  |  |  |  |  |  |  |  |  |  |  |  |  |  |  |  |  |  |  |  |
| P3H01SE |  | H01 HVAC Eqt. - 1stGoods arr. at Site CA12 TealB | milestone | 0d | 2011-11-24 | 2011-11-24 | P3H01P SF+240d |  | 128d | 59.5d | TB26 - 2 - Manuf and Delivy |  |  |  | P3H01SE | P3H01SE | 860 | H01 | 12 | H01 | 000 | 200 | 400 | P | SC | L2 | P | H | PH19 | 1222 | hva_as | LND |  |  |  |
|  | B | **B Mechanical - Stationary Equipment** |  |  | 2010-11-30 | 2011-10-13 |  |  |  |  |  |  |  |  |  |  |  |  |  |  |  |  |  |  |  |  |  |  |  |  |  |  |  |  |  |
| P3A13S1B |  | A13 Scales - Goods arr. at Site CA12 (MI-21106) | milestone | 0d | 2010-11-30 A | 2010-11-30 A | P3A13N FF | 100% |  |  | TB26 - 2 - Manuf and Delivy |  |  |  | P3A13S1B | P3A13S1B | 860 | A13 | 12 | 2DC9060 | 200 | 200 | 400 | P | OWN | 0 | P | B | PB99 | 1222 | S | LND |  |  |  |
| P3A11S1 |  | A11 Unloading Arms - Goods arrived at Site CA12 | milestone | 0d | 2011-10-13 | 2011-10-13 | P3A11N FF, P3A11G |  | 39d | 24.5d | TB26 - 2 - Manuf and Delivy |  | 14,404 |  | P3A11S1 | P3A11S1 | 860 | A11 | 12 | 2KB4420 | 200 | 200 | 400 | P | OWN | 0 | P | B | PB99 | 1222 | S | LND |  |  |  |
|  | M | **M Mechanical - Rotating Equipment** |  |  | 2011-03-31 | 2011-03-31 |  |  |  |  |  |  |  |  |  |  |  |  |  |  |  |  |  |  |  |  |  |  |  |  |  |  |  |  |  |
| P3M08S1B |  | M08 Teal Pump - Good arr. at Site CA12 P-21102 | milestone | 0d | 2011-03-31 A | 2011-03-31 A | P3M08N FF | 100% |  |  | TB26 - 2 - Manuf and Delivy |  |  |  | P3M08S1B | P3M08S1B | 860 | M08 | 12 | 2PA6690 | 200 | 200 | 400 | P | OWN | 0 | P | M | PM29 | 1222 | S | LND |  |  |  |
|  | 1232 | **1232 Recycle Gas Compressor - CA12** |  |  | 2011-01-17 | 2011-01-17 |  |  |  |  |  |  |  |  |  |  |  |  |  |  |  |  |  |  |  |  |  |  |  |  |  |  |  |  |  |
|  | M | **M Mechanical - Rotating Equipment** |  |  | 2011-01-17 | 2011-01-17 |  |  |  |  |  |  |  |  |  |  |  |  |  |  |  |  |  |  |  |  |  |  |  |  |  |  |  |  |  |
| P3M02S1 |  | M02 Recycle Gas C. - Goods arrived at site CA12 | milestone | 0d | 2011-01-17 A | 2011-01-17 A | P3M02G, P3M02N3 FF, E3M0270, HPMM02 FF, P3M02N FF | 100% |  |  | TB26 - 2 - Manuf and Delivy |  | 479,608 | 479,608 | P3M02S1 | P3M02S1 | 860 | M02 | 12 | 2DC8490 | 200 | 200 | 400 | P | OWN | C2 | P | M | PM19 | 1232 | S | LND | DC |  |  |
|  | 1233 | **1233 Bleed Booster Compressor - CA12** |  |  | 2011-06-29 | 2011-06-29 |  |  |  |  |  |  |  |  |  |  |  |  |  |  |  |  |  |  |  |  |  |  |  |  |  |  |  |  |  |
|  | M | **M Mechanical - Rotating Equipment** |  |  | 2011-06-29 | 2011-06-29 |  |  |  |  |  |  |  |  |  |  |  |  |  |  |  |  |  |  |  |  |  |  |  |  |  |  |  |  |  |
| P3M04S |  | M04 GasBleedCompr. - Goods arrived at site CA12 | milestone | 0d | 2011-06-29 A | 2011-06-29 A | P3M04N FF, HPMM04 FF, P3M04G | 100% |  |  | TB26 - 2 - Manuf and Delivy |  | 50,600 | 50,600 | P3M04S | P3M04S | 860 | M04 | 12 | 2KB4360 | 200 | 200 | 400 | P | OWN | C2 | P | M | PM19 | 1233 | S | LND | DC |  |  |
|  | 13 | **13 CA13 - Polymerization Line 2** |  |  | 2008-09-06 | 2012-02-25 |  |  |  |  |  |  |  |  |  |  |  |  |  |  |  |  |  |  |  |  |  |  |  |  |  |  |  |  |  |
|  | 1301 | **1301 Reactor Structure - CA13** |  |  | 2010-08-25 | 2012-02-25 |  |  |  |  |  |  |  |  |  |  |  |  |  |  |  |  |  |  |  |  |  |  |  |  |  |  |  |  |  |
|  | N | **N Structural Steel** |  |  | 2010-11-23 | 2011-05-06 |  |  |  |  |  |  |  |  |  |  |  |  |  |  |  |  |  |  |  |  |  |  |  |  |  |  |  |  |  |
| P3N02GE |  | CA13 ReactorStr SK1301 - Vendor Procurement |  | 40d | 2010-11-23 A | 2011-01-04 A | EN27130110 | 100% |  |  | TB26 - 2 - Manuf and Delivy |  |  |  | P3N02GE | P3N02GE | 860 | N02G | 13 | N02G | 200 | 200 | 400 | P | Chel | 0 | P | N | PN25 | 1301 | SS | LND |  | DEL |  |
| P3N02GL |  | CA13 ReactorStr SK1301 - Vendor Fabrication |  | 119d | 2010-12-20 A | 2011-04-20 A | EN281301 SS+13d, P3N02GE SS+20d | 100% |  |  | TB26 - 2 - Manuf and Delivy |  |  |  | P3N02GL | P3N02GL | 860 | N02G | 13 | N02G | 200 | 200 | 400 | P | Chel | 0 | P | N | PN26 | 1301 | SS | LND |  | DEL |  |
| PN661301 |  | CA13 ReactorStr SK1301 - Fabrication Gratings |  | 113d | 2010-12-28 A | 2011-04-20 A | EN681301, EN641301 FF | 100% |  |  | TB26 - 2 - Manuf and Delivy |  |  |  | PN661301 | PN661301 | 860 | N02G | 13 | N02G | 200 | 200 |  | C |  |  | P | N | PN66 | 1301 | SS | LND |  |  |  |
| P3N02GP |  | CA13 ReactorStr SK1301 - Transport to Site |  | 81d | 2011-02-14 A | 2011-05-06 A | P3N02GL FF+10d | 100% |  |  | TB26 - 2 - Manuf and Delivy | Piperacks, Main Structures (Delivery) [704 t]; Ladders & Platforms (Delivery) [31 t] |  |  | P3N02GP | P3N02GP | 860 | N02G | 13 | N02G | 200 | 200 | 400 | P | Chel | 0 | P | N | PN28 | 1301 | SS | LND |  |  | 0,00 |
| PN681301 |  | CA13 ReactorStr SK1301-Transport Gratings toSite |  | 81d | 2011-02-14 A | 2011-05-06 A | PN661301 FF+10d | 100% |  |  | TB26 - 2 - Manuf and Delivy |  |  |  | PN681301 | PN681301 | 860 | N02G | 13 | N02G | 200 | 200 |  | C |  |  | P | N | PN68 | 1301 | SS | LND |  |  |  |
| P3N02GN |  | CA13 ReactorStr SK1301 - Goods arrived at Site 1st LOT | milestone | 0d | 2011-02-23 A | 2011-02-23 A | P3N100 FF, P3N02GP SF+10d | 100% |  |  | TB26 - 2 - Manuf and Delivy |  |  |  | P3N02GN | P3N02GN | 860 | N02G | 13 | N02G | 200 | 200 | 400 | P | Chel | L2 | P | N | PN29 | 1301 | M | LND |  |  |  |
| PN691301 |  | CA13 ReactorStr SK1301 -Gratings arrived at Site | milestone | 0d | 2011-02-23 A | 2011-02-23 A | PN681301 SF+10d | 100% |  |  | TB26 - 2 - Manuf and Delivy |  |  |  | PN691301 | PN691301 | 860 | N02G | 13 | N02G | 200 | 200 |  | C |  |  | P | N | PN69 | 1301 | S | LND |  |  |  |
|  | U | **U Package Units** |  |  | 2011-08-30 | 2011-08-30 |  |  |  |  |  |  |  |  |  |  |  |  |  |  |  |  |  |  |  |  |  |  |  |  |  |  |  |  |  |
| P3U15S2 |  | PU15 Reactor Seal Oil P.- Goods arr.at Site CA13 | milestone | 0d | 2011-08-30 A | 2011-08-30 A | P3U15G, P3U15N FF | 100% |  |  | TB26 - 2 - Manuf and Delivy |  |  |  | P3U15S2 | P3U15S2 | 860 | PU15 | 13 | 2DC8910 | 200 | 200 | 400 | P | OWN | 0 | P | U | PU99 | 1301 | S | LND |  |  |  |

Notes:
- P3H01SE: UDF_Actictity Name (Russia): H01 Оборудование ОВКВ - Прибытие 1-й партии товара на площадку, CA12 Здание ТЭА
- P3A11S1: Expenses: 900A 14404
- P3M02S1: Expenses: 900A 479608
- P3M04S: P3 Activity Log Info: Delivery DDU / Tobolsk / Expenses: 900A 50600
- P3N02GN: UDF_Actictity Name (Russia): CA13 Конструкция реактора SK1301 - Прибытие товара на площадку

| ID | WBS | Activity | Type | Duration | Start | Finish | Predecessors | Complete | Total float | Free float | Calendar | Resources | Cost | Actual cost | UDF_SAVE ACTID | UDF_SAVE ACT ID | Department | Type of Work | Constr. Area | Pro Unit/DocCode | Inquiry/Order No | PMT-Area | PMT-Schedule Org | PMT-Discipline | PMT-Phase | PMT-Respons. | Zeigen/n. Zeigen | WBS Phase | WBS Discipline | WBS Type of Work | WBS Objects | IMS | UPT | TB26 Ressource Budget | WEIGHT | UDF_LEVEL | UDF_PO No | UDF_TAG No | UDF_Object No | UDF_DELIVERY DATE PO | UDF_DELIVERY DATE DISPATCH PLANNED | UDF_DELIVERY DATE TO SITE PLANNED | UDF_DELIVERY DATE SITE NEED DATE | UDF_PACKAGE | UDF_SUPPLIER | UDF_CHECK BASELINE | UDF_Weight (ton) | UDF_CONTRACT INDICATOR | PMT-Doc. Type |
| --- | --- | --- | --- | --- | --- | --- | --- | --- | --- | --- | --- | --- | --- | --- | --- | --- | --- | --- | --- | --- | --- | --- | --- | --- | --- | --- | --- | --- | --- | --- | --- | --- | --- | --- | --- | --- | --- | --- | --- | --- | --- | --- | --- | --- | --- | --- | --- | --- | --- |
|  | B | **B Mechanical - Stationary Equipment** |  |  | 2010-08-25 | 2011-10-20 |  |  |  |  |  |  |  |  |  |  |  |  |  |  |  |  |  |  |  |  |  |  |  |  |  |  |  |  |  |  |  |  |  |  |  |  |  |  |  |  |  |  |  |
| P3A04S2 |  | A04 R Overhead Sep. - Goods arrived at site CA13 | milestone | 0d | 2010-08-25 A | 2010-08-25 A | P3A04N FF, P3A04N5 FF | 100% |  |  | TB26 - 2 - Manuf and Delivy |  |  |  | P3A04S2 | P3A04S2 | 860 | A04 | 13 | DC | 2DC8500 | 200 | 200 | 400 | P | OWN | C2 | P | B | PB19 | 1301 | S | LND |  |  |  |  |  |  |  |  |  |  |  |  |  |  |  |  |
| P3ALL1S2 |  | ALL1 React w Agitat - Goods arrived at site CA13 | milestone | 0d | 2010-08-28 A | 2010-08-28 A | P3ALL1N5 FF, P3ALL1N FF | 100% |  |  | TB26 - 2 - Manuf and Delivy |  |  |  | P3ALL1S2 | P3ALL1S2 | 860 | ALL1 | 13 | DC | 2DC8440 | 200 | 200 | 400 | P | OWN | C2 | P | B | PB39 | 1301 | S | LND |  |  |  |  |  |  |  |  |  |  |  |  |  |  |  |  |
| P3A05S2 |  | A05 Offgas Cycl & R - Goods arrived at site CA13 | milestone | 0d | 2010-10-30 A | 2010-10-30 A | P3A05N FF | 100% |  |  | TB26 - 2 - Manuf and Delivy |  |  |  | P3A05S2 | P3A05S2 | 860 | A05 | 13 | DC | 2DC8590 | 200 | 200 | 400 | P | OWN | C2 | P | B | PB19 | 1301 | S | LND |  |  |  |  |  |  |  |  |  |  |  |  |  |  |  |  |
| P3A04AS2 |  | A04A R Overhead Cond- Goods arrived at site CA13 | milestone | 0d | 2010-12-20 A | 2010-12-20 A | P3A04AN FF | 100% |  |  | TB26 - 2 - Manuf and Delivy |  | 197,700 | 197,700 | P3A04AS2 | P3A04AS2 | 860 | A04A | 13 | DC | 2DC9110 | 200 | 200 | 400 | P | OWN | C2 | P | B | PB19 | 1301 | S | LND |  |  |  |  |  |  |  |  |  |  |  |  |  |  |  |  |
| P3A07S2 |  | A07 R Fines Eductor - Goods arrived at site CA13 | milestone | 0d | 2011-01-05 A | 2011-01-05 A | P3A07N FF | 100% |  |  | TB26 - 2 - Manuf and Delivy |  |  |  | P3A07S2 | P3A07S2 | 860 | A07 | 13 | DC | 2DC8640 | 200 | 200 | 400 | P | OWN | C2 | P | B | PB99 | 1301 | S | LND |  |  |  |  |  |  |  |  |  |  |  |  |  |  |  |  |
| V-22221 |  | INSTRUMENT AIR VESSEL |  | 12.5d | 2011-05-03 A | 2011-05-18 A |  | 100% |  |  | TB26 - 3 - Construct-normal * | Static Equipment < 10 tons [1 t]; Static equipment < 10t [100 h] | 4,000 | 4,000 |  | V-22221 |  |  | 13 |  |  |  |  |  |  |  | EQ | X | B |  | 1301 |  |  | 100,00 | 1000 | structure | 2 DD 8530 | V-22221 | SK1201 | 2010-10-02 | 2010-11-30 | 2011-02-10 | 2010-12-23 | A02C INSTRUMENT AIR VESSELS | Linde E. India | x |  |  |  |
| P3A12S5 |  | A12 Overhead Cranes - Goods arrived at Site CA13 | milestone | 0d | 2011-09-25 | 2011-09-25 | P3A12N |  | -40d | 0d | TB26 - 2 - Manuf and Delivy |  |  |  | P3A12S5 | P3A12S5 | 860 | A12 | 13 |  | 2KB4740 | 200 | 200 | 400 | P | OWN | 0 | P | B | PB99 | 1301 | S | LND |  |  |  |  |  |  |  |  |  |  |  |  |  |  |  |  |
| P3A06S2 |  | A06 Start-Up Heater/Condenser - Goods arrived at Site CA13 | milestone | 0d | 2011-10-08 | 2011-10-08 | P3A06N FF |  | -82d | 1d | TB26 - 2 - Manuf and Delivy |  |  |  | P3A06S2 | P3A06S2 | 860 | A06 | 13 |  | 2DD8530 | 200 | 200 | 400 | P | OWN | 0 | P | B | PB29 | 1301 | S | LND |  |  |  |  |  |  |  |  |  |  |  |  |  |  |  |  |
| V-22222 |  | INSTRUMENT AIR VESSEL |  | 10d | 2011-10-10 | 2011-10-20 | P3A02CS1, AG-22201-MI01 (other project), ER291300, XN601301 (other project), XN201301u (other project) |  | -61d | 10d | TB26 - 3 - Construct-normal * | Static Equipment < 10 tons [1 t]; Static equipment < 10t [100 h] | 4,000 |  |  | V-22222 |  |  | 13 |  |  |  |  |  |  |  | EQ | X | B |  | 1301 |  |  | 100,00 | 1000 | concrete +0.00 | 2 DD 8530 | V-22221 | SK1201 | 2010-10-02 | 2010-11-30 | 2011-02-10 | 2010-12-23 | A02C INSTRUMENT AIR VESSELS | Linde E. India | x | 1,2 | UDF_G3 |  |
|  | M | **M Mechanical - Rotating Equipment** |  |  | 2011-01-26 | 2011-03-31 |  |  |  |  |  |  |  |  |  |  |  |  |  |  |  |  |  |  |  |  |  |  |  |  |  |  |  |  |  |  |  |  |  |  |  |  |  |  |  |  |  |  |  |
| P3M05S2 |  | M05 R. Quench Pumps - Goods arrived at site CA13 | milestone | 0d | 2011-01-26 A | 2011-01-26 A | P3M05N FF | 100% |  |  | TB26 - 2 - Manuf and Delivy |  |  |  | P3M05S2 | P3M05S2 | 860 | M05 | 13 | DC | 2PA6550 | 200 | 200 | 400 | P | OWN | C2 | P | M | PM29 | 1301 | S | LND |  |  |  |  |  |  |  |  |  |  |  |  |  |  |  |  |
| P3M06S2 |  | M06 R. Tepid Pumps - Goods arrived at site CA13 | milestone | 0d | 2011-01-26 A | 2011-01-26 A | P3M06N FF | 100% |  |  | TB26 - 2 - Manuf and Delivy |  |  |  | P3M06S2 | P3M06S2 | 860 | M06 | 13 | DC | 2PA6540 | 200 | 200 | 400 | P | OWN | C2 | P | M | PM29 | 1301 | S | LND |  |  |  |  |  |  |  |  |  |  |  |  |  |  |  |  |
| P3M11S2 |  | M11 RA Gear Unit - Goods arrived at site CA13 | milestone | 0d | 2011-03-31 A | 2011-03-31 A | P3M11N FF | 100% |  |  | TB26 - 2 - Manuf and Delivy |  |  |  | P3M11S2 | P3M11S2 | 860 | M11 | 13 | DC | 2KB4290 | 200 | 200 | 400 | P | OWN | C2 | P | M | PM99 | 1301 | S | LND |  |  |  |  |  |  |  |  |  |  |  |  |  |  |  |  |
|  | J | **J Instrumentation** |  |  | 2012-02-25 | 2012-02-25 |  |  |  |  |  |  |  |  |  |  |  |  |  |  |  |  |  |  |  |  |  |  |  |  |  |  |  |  |  |  |  |  |  |  |  |  |  |  |  |  |  |  |  |
| P3J03S2 |  | J03 Nuclear L. Meas.- Goods arrived at Site CA13 | milestone | 0d | 2012-02-25 | 2012-02-25 | P3J03N FF |  | -78d | 74d | TB26 - 2 - Manuf and Delivy |  |  |  | P3J03S2 | P3J03S2 | 860 | J03 | 13 |  | 2JD7540 | 200 | 200 | 400 | P | OWN | 0 | P | J | PJ39 | 1301 | IT | LND |  |  |  |  |  |  |  |  |  |  |  |  |  |  |  |  |
|  | 1303 | **1303 Connection Structure to Extruder Bldg. - CA13** |  |  | 2011-03-05 | 2011-05-29 |  |  |  |  |  |  |  |  |  |  |  |  |  |  |  |  |  |  |  |  |  |  |  |  |  |  |  |  |  |  |  |  |  |  |  |  |  |  |  |  |  |  |  |
|  | N | **N Structural Steel** |  |  | 2011-03-05 | 2011-05-29 |  |  |  |  |  |  |  |  |  |  |  |  |  |  |  |  |  |  |  |  |  |  |  |  |  |  |  |  |  |  |  |  |  |  |  |  |  |  |  |  |  |  |  |
| P3N02IE |  | CA13 SB1303 - Vendor Procurement |  | 35d | 2011-03-05 A | 2011-04-08 A | EN27130310 | 100% |  |  | TB26 - 2 - Manuf and Delivy |  |  |  | P3N02IE | P3N02IE | 860 | N02I | 13 |  | N02I | 200 | 200 | 400 | P | Chel | 0 | P | N | PN25 | 1303 | SS | LND |  |  |  |  |  |  |  |  |  |  |  |  |  |  |  | DEL |
| P3N02IL |  | CA13 SB1303 - Vendor Fabrication |  | 40d | 2011-04-09 A | 2011-05-19 A | EN281303 SS+25d, P3N02IE SS+25d | 100% |  |  | TB26 - 2 - Manuf and Delivy |  |  |  | P3N02IL | P3N02IL | 860 | N02I | 13 |  | N02I | 200 | 200 | 400 | P | Chel | 0 | P | N | PN26 | 1303 | SS | LND |  |  |  |  |  |  |  |  |  |  |  |  |  |  |  | DEL |
| P3N02IP |  | CA13 SB1303 - Transport to Site |  | 10d | 2011-05-20 A | 2011-05-29 A | P3N02IL | 100% |  |  | TB26 - 2 - Manuf and Delivy | Piperacks, Main Structures (Delivery) [54 t]; Ladders & Platforms (Delivery) [3 t] |  |  | P3N02IP | P3N02IP | 860 | N02I | 13 |  | N02I | 200 | 200 | 400 | P | Chel | 0 | P | N | PN28 | 1303 | SS | LND | 0,00 |  |  |  |  |  |  |  |  |  |  |  |  |  |  |  |
| P3N02IN |  | CA13 SB1303 - Goods arrived at Site | milestone | 0d | 2011-05-29 A | 2011-05-29 A | P3N02IP FF, P3N100 FF | 100% |  |  | TB26 - 2 - Manuf and Delivy |  |  |  | P3N02IN | P3N02IN | 860 | N02I | 13 |  | N02I | 200 | 200 | 400 | P | Chel | L2 | P | N | PN29 | 1303 | M | LND |  |  |  |  |  |  |  |  |  |  |  |  |  |  |  |  |
|  | 1304 | **1304 Connection Structure Reactor to Teal Bldg - CA13** |  |  | 2010-11-01 | 2011-03-21 |  |  |  |  |  |  |  |  |  |  |  |  |  |  |  |  |  |  |  |  |  |  |  |  |  |  |  |  |  |  |  |  |  |  |  |  |  |  |  |  |  |  |  |
|  | N | **N Structural Steel** |  |  | 2010-11-01 | 2011-03-21 |  |  |  |  |  |  |  |  |  |  |  |  |  |  |  |  |  |  |  |  |  |  |  |  |  |  |  |  |  |  |  |  |  |  |  |  |  |  |  |  |  |  |  |
| P3N02HE |  | CA13 TealStr SK1304 - Vendor Procurement |  | 35d | 2010-11-01 A | 2010-12-05 A | EN27130410 FS+5d | 100% |  |  | TB26 - 2 - Manuf and Delivy |  |  |  | P3N02HE | P3N02HE | 860 | N02H | 13 |  | N02H | 200 | 200 | 400 | P | Chel | 0 | P | N | PN25 | 1304 | SS | LND |  |  |  |  |  |  |  |  |  |  |  |  |  |  |  | DEL |
| PN661304 |  | CA13 TealStr SK1302/4 - Fabrication Gratings |  | 80d | 2010-11-19 A | 2011-02-09 A | EN641304 FF, EN681304 | 100% |  |  | TB26 - 2 - Manuf and Delivy |  |  |  | PN661304 | PN661304 | 860 | XNK | 13 |  |  | 200 | 200 |  | C |  |  | P | N | PN66 | 1304 | SS | LND |  |  |  |  |  |  |  |  |  |  |  |  |  |  |  |  |
| P3N02HL |  | CA13 TealStr SK1304 - Vendor Fabrication |  | 78d | 2010-12-19 A | 2011-03-09 A | EN281304 SS+25d, P3N02HE SS+20d, EN281304 FF+12d | 100% |  |  | TB26 - 2 - Manuf and Delivy |  |  |  | P3N02HL | P3N02HL | 860 | N02H | 13 |  | N02H | 200 | 200 | 400 | P | Chel | 0 | P | N | PN26 | 1304 | SS | LND |  |  |  |  |  |  |  |  |  |  |  |  |  |  |  | DEL |
| PN681304 |  | CA13 TealStr SK1302/4-Transport Gratings to Site |  | 10d | 2011-02-10 A | 2011-02-19 A | PN661304 | 100% |  |  | TB26 - 2 - Manuf and Delivy |  |  |  | PN681304 | PN681304 | 860 | XNK | 13 |  |  | 200 | 200 |  | C |  |  | P | N | PN68 | 1304 | SS | LND |  |  |  |  |  |  |  |  |  |  |  |  |  |  |  |  |
| PN691304 |  | CA13 TealStr SK1302/4 - Gratings arrived at Site | milestone | 0d | 2011-02-19 A | 2011-02-19 A | PN681304 FF | 100% |  |  | TB26 - 2 - Manuf and Delivy |  |  |  | PN691304 | PN691304 | 860 | XNK | 13 |  |  | 200 | 200 |  | C |  |  | P | N | PN69 | 1304 | S | LND |  |  |  |  |  |  |  |  |  |  |  |  |  |  |  |  |
| P3N02HP |  | CA13 TealStr SK1304 - Transport to Site |  | 24d | 2011-02-26 A | 2011-03-21 A | P3N02HL | 100% |  |  | TB26 - 2 - Manuf and Delivy | Piperacks, Main Structures (Delivery) [60 t]; Ladders & Platforms (Delivery) [1 t] |  |  | P3N02HP | P3N02HP | 860 | N02H | 13 |  | N02H | 200 | 200 | 400 | P | Chel | 0 | P | N | PN28 | 1304 | SS | LND | 0,00 |  |  |  |  |  |  |  |  |  |  |  |  |  |  |  |
| P3N02HN |  | CA13 TealStr SK1304 - Goods arrived at Site | milestone | 0d | 2011-03-21 A | 2011-03-21 A | P3N02HP FF | 100% |  |  | TB26 - 2 - Manuf and Delivy |  |  |  | P3N02HN | P3N02HN | 860 | N02H | 13 |  | N02H | 200 | 200 | 400 | P | Chel | L2 | P | N | PN29 | 1304 | M | LND |  |  |  |  |  |  |  |  |  |  |  |  |  |  |  |  |

Notes:
- P3A04AS2: P3 Activity Log Info: Delivery DDU / Tobolsk / Expenses: 900A 197700
- P3J03S2: P3 Activity Log Info: as late / as possible to install just in / time
- P3N02IN: UDF_Actictity Name (Russia): CA13 Соединительные конструкции SK1303 - Прибытие товара на площадку
- P3N02HN: UDF_Actictity Name (Russia): CA13 Здание ТЭА SK1302/4 - Прибытие товара на площадку

| ID | WBS | Activity | Type | Duration | Start | Finish | Predecessors | Complete | Total float | Free float | Calendar | Resources | UDF_SAVE ACTID | UDF_SAVE ACT ID | Department | Type of Work | Constr. Area | PMT-Area | PMT-Schedule Org | PMT-Phase | WBS Phase | WBS Discipline | WBS Type of Work | WBS Objects | IMS | UPT | Inquiry/Order No | PMT-Discipline | PMT-Doc. Type | PMT-Respons. | Zeigen/n. Zeigen | TB26 Ressource Budget |
| --- | --- | --- | --- | --- | --- | --- | --- | --- | --- | --- | --- | --- | --- | --- | --- | --- | --- | --- | --- | --- | --- | --- | --- | --- | --- | --- | --- | --- | --- | --- | --- | --- |
|  | 1305 | **1305 Agitator Removable Unit - CA13** |  |  | 2010-11-25 | 2011-07-14 |  |  |  |  |  |  |  |  |  |  |  |  |  |  |  |  |  |  |  |  |  |  |  |  |  |  |
|  | N | **N Structural Steel** |  |  | 2010-11-25 | 2011-03-07 |  |  |  |  |  |  |  |  |  |  |  |  |  |  |  |  |  |  |  |  |  |  |  |  |  |  |
| PN661305 |  | CA13 Agitator SK1305 - Fabrication Gratings |  | 50d | 2010-11-25 A | 2011-01-16 A | EN681305, EN641305 FF | 100% |  |  | TB26 - 2 - Manuf and Delivy |  | PN661305 | PN661305 | 860 | XNK | 13 | 200 | 200 | C | P | N | PN66 | 1305 | SS | LND |  |  |  |  |  |  |
| P3N02JE |  | CA13 Agitator SK1305 - Vendor Procurement |  | 25d | 2010-11-30 A | 2010-12-24 A | EN27130510 | 100% |  |  | TB26 - 2 - Manuf and Delivy |  | P3N02JE | P3N02JE | 860 | N02J | 13 | 200 | 200 | P | P | N | PN25 | 1305 | SS | LND | N02J | 400 | DEL | Chel | 0 |  |
| P3N02JL |  | CA13 Agitator SK1305 - Vendor Fabrication |  | 60d | 2010-12-27 A | 2011-02-25 A | P3N02JE SS+20d, EN281305 SS+13d, EN281305 FF+16d | 100% |  |  | TB26 - 2 - Manuf and Delivy |  | P3N02JL | P3N02JL | 860 | N02J | 13 | 200 | 200 | P | P | N | PN26 | 1305 | SS | LND | N02J | 400 | DEL | Chel | 0 |  |
| PN681305 |  | CA13 Agitator SK1305 - Transport Gratings toSite |  | 10d | 2011-01-17 A | 2011-01-26 A | PN661305 | 100% |  |  | TB26 - 2 - Manuf and Delivy |  | PN681305 | PN681305 | 860 | XNK | 13 | 200 | 200 | C | P | N | PN68 | 1305 | SS | LND |  |  |  |  |  |  |
| PN691305 |  | CA13 Agitator SK1305 - Gratings arrived at Site | milestone | 0d | 2011-01-26 A | 2011-01-26 A | PN681305 FF | 100% |  |  | TB26 - 2 - Manuf and Delivy |  | PN691305 | PN691305 | 860 | XNK | 13 | 200 | 200 | C | P | N | PN69 | 1305 | S | LND |  |  |  |  |  |  |
| P3N02JP |  | CA13 Agitator SK1305 - Transport to Site |  | 10d | 2011-02-26 A | 2011-03-07 A | P3N02JL | 100% |  |  | TB26 - 2 - Manuf and Delivy | Piperacks, Main Structures (Delivery) [115 t]; Ladders & Platforms (Delivery) [4 t] | P3N02JP | P3N02JP | 860 | N02J | 13 | 200 | 200 | P | P | N | PN28 | 1305 | SS | LND | N02J | 400 |  | Chel | 0 | 0,00 |
| P3N02JN |  | CA13 Agitator SK1305 - Goods arrived at Site | milestone | 0d | 2011-03-07 A | 2011-03-07 A | P3N02JP FF | 100% |  |  | TB26 - 2 - Manuf and Delivy |  | P3N02JN | P3N02JN | 860 | N02J | 13 | 200 | 200 | P | P | N | PN29 | 1305 | M | LND | N02J | 400 |  | Chel | L2 |  |
|  | J | **J Instrumentation** |  |  | 2011-07-14 | 2011-07-14 |  |  |  |  |  |  |  |  |  |  |  |  |  |  |  |  |  |  |  |  |  |  |  |  |  |  |
| P3J07S2 |  | J07 Analyser System - Goods arrived at Site CA13 | milestone | 0d | 2011-07-14 A | 2011-07-14 A | P3J07N FF | 100% |  |  | TB26 - 2 - Manuf and Delivy |  | P3J07S2 | P3J07S2 | 860 | J07 | 13 | 200 | 200 | P | P | J | PJ39 | 1305 | IT | LND | 2JD7560 | 400 |  | OWN | 0 |  |
|  | 1321 | **1321 Catalyst Building Line 2 - CA13** |  |  | 2010-11-30 | 2011-12-14 |  |  |  |  |  |  |  |  |  |  |  |  |  |  |  |  |  |  |  |  |  |  |  |  |  |  |
|  | N | **N Structural Steel** |  |  | 2011-03-12 | 2011-05-12 |  |  |  |  |  |  |  |  |  |  |  |  |  |  |  |  |  |  |  |  |  |  |  |  |  |  |
| P3N02$E |  | CA13 Catalyst Bldg SK1306 - Vendor Procurement |  | 25d | 2011-03-12 A | 2011-04-05 A | EN271321 | 100% |  |  | TB26 - 2 - Manuf and Delivy |  | P3N02$E | P3N02$E | 860 | N02$ | 13 | 200 | 200 | P | P | N | PN25 | 1321 | SS | LND | N02$ | 400 | DEL | Chel | 0 |  |
| P3N02$L |  | CA13 Catalyst Bldg SK1306 - Vendor Fabrication |  | 35d | 2011-04-02 A | 2011-05-07 A | P3N02$E SS+15d, EN281321 SS+15d | 100% |  |  | TB26 - 2 - Manuf and Delivy |  | P3N02$L | P3N02$L | 860 | N02$ | 13 | 200 | 200 | P | P | N | PN26 | 1321 | SS | LND | N02$ | 400 | DEL | Chel | 0 |  |
| P3N02$P |  | CA13 Catalyst Bldg SK1306 - Transport to Site |  | 5d | 2011-05-08 A | 2011-05-12 A | P3N02$L | 100% |  |  | TB26 - 2 - Manuf and Delivy | Piperacks, Main Structures (Delivery) [40 t]; Ladders & Platforms (Delivery) [3 t] | P3N02$P | P3N02$P | 860 | N02$ | 13 | 200 | 200 | P | P | N | PN28 | 1321 | SS | LND | N02$ | 400 |  | Chel | 0 | 0,00 |
| P3N02$N |  | CA13 Catalyst Bldg SK1306 - Goods arrived at Site | milestone | 0d | 2011-05-12 A | 2011-05-12 A | P3N02$P FF | 100% |  |  | TB26 - 2 - Manuf and Delivy |  | P3N02$N | P3N02$N | 860 | N02$ | 13 | 200 | 200 | P | P | N | PN29 | 1321 | M | LND | N02$ | 400 |  | Chel | L2 |  |
|  | H | **H HVAC** |  |  | 2011-12-14 | 2011-12-14 |  |  |  |  |  |  |  |  |  |  |  |  |  |  |  |  |  |  |  |  |  |  |  |  |  |  |
| P3H01SF |  | H01 HVAC Eqt. - 1stGoods arr. at Site CA13 CatB | milestone | 0d | 2011-12-14 | 2011-12-14 | P3H01P SF+260d |  | 85d | 96d | TB26 - 2 - Manuf and Delivy |  | P3H01SF | P3H01SF | 860 | H01 | 13 | 000 | 200 | P | P | H | PH19 | 1321 | hva_as | LND | H01 | 400 |  | SC | L2 |  |
|  | B | **B Mechanical - Stationary Equipment** |  |  | 2010-11-30 | 2011-10-08 |  |  |  |  |  |  |  |  |  |  |  |  |  |  |  |  |  |  |  |  |  |  |  |  |  |  |
| P3A13S2A |  | A13 Scales - Goods arr. at Site CA13 (MI-22104) | milestone | 0d | 2010-11-30 A | 2010-11-30 A | P3A13N FF | 100% |  |  | TB26 - 2 - Manuf and Delivy |  | P3A13S2A | P3A13S2A | 860 | A13 | 13 | 200 | 200 | P | P | B | PB99 | 1321 | S | LND | 2DC9060 | 400 |  | OWN | 0 |  |
| P3A03S2 |  | A03 Cat Drum Roller - Goods arrived at Site CA13 | milestone | 0d | 2011-01-05 A | 2011-01-05 A | P3A03N FF | 100% |  |  | TB26 - 2 - Manuf and Delivy |  | P3A03S2 | P3A03S2 | 860 | A03 | 13 | 200 | 200 | P | P | B | PB99 | 1321 | S | LND | 2DC9630 | 400 |  | OWN | 0 |  |
| P3A01S2 |  | A01 Drums/Small V. - Goods arrived at Site CA13 | milestone | 0d | 2011-10-08 | 2011-10-08 | P3A01N FF |  | 6d | 79d | TB26 - 2 - Manuf and Delivy |  | P3A01S2 | P3A01S2 | 860 | A01 | 13 | 200 | 200 | P | P | B | PB19 | 1321 | S | LND | 2DD8530 | 400 |  | OWN | 0 |  |
|  | M | **M Mechanical - Rotating Equipment** |  |  | 2011-03-31 | 2011-06-24 |  |  |  |  |  |  |  |  |  |  |  |  |  |  |  |  |  |  |  |  |  |  |  |  |  |  |
| P3M08S2A |  | M08 Donor Pump - Good arr. at Site CA13 P-22103 | milestone | 0d | 2011-03-31 A | 2011-03-31 A | P3M08N FF | 100% |  |  | TB26 - 2 - Manuf and Delivy |  | P3M08S2A | P3M08S2A | 860 | M08 | 13 | 200 | 200 | P | P | M | PM29 | 1321 | S | LND | 2PA6690 | 400 |  | OWN | 0 |  |
| P3M10S2 |  | M10 Cat. Waste Pumps- Goods arrived at Site CA13 | milestone | 0d | 2011-03-31 A | 2011-03-31 A | P3M10N | 100% |  |  | TB26 - 2 - Manuf and Delivy |  | P3M10S2 | P3M10S2 | 860 | M10 | 13 | 200 | 200 | P | P | M | PM29 | 1321 | S | LND | 2PA6690 | 400 |  | OWN | 0 |  |
| P3M09S2 |  | M09 Unloading Pumps - Goods arrived at Site CA13 | milestone | 0d | 2011-06-01 A | 2011-06-01 A | P3M09N FF | 100% |  |  | TB26 - 2 - Manuf and Delivy |  | P3M09S2 | P3M09S2 | 860 | M09 | 13 | 200 | 200 | P | P | M | PM29 | 1321 | S | LND | 2PA6680 | 400 |  | OWN | 0 |  |
| P3M07S2 |  | M07 Cat Feed Pumps - Goods arrived at Site CA13 | milestone | 0d | 2011-06-24 A | 2011-06-24 A | P3M07N FF | 100% |  |  | TB26 - 2 - Manuf and Delivy |  | P3M07S2 | P3M07S2 | 860 | M07 | 13 | 200 | 200 | P | P | M | PM29 | 1321 | S | LND | 2PA6670 | 400 |  | OWN | 0 |  |

Notes:
- P3N02JN: UDF_Actictity Name (Russia): CA13 Мешалка SK1305 - Прибытие товара на площадку
- P3N02$N: UDF_Actictity Name (Russia): CA12 Мешалка SK1205 - Прибытие товара на площадку
- P3H01SF: UDF_Actictity Name (Russia): H01 Оборудование ОВКВ - Прибытие 1-й партии товара на площадку, CA13 Здание катализатора

| ID | WBS | Activity | Type | Duration | Start | Finish | Predecessors | Complete | Total float | Free float | Calendar | Resources | UDF_SAVE ACTID | UDF_SAVE ACT ID | Department | Type of Work | Constr. Area | Inquiry/Order No | PMT-Area | PMT-Schedule Org | PMT-Discipline | PMT-Phase | PMT-Doc. Type | PMT-Respons. | Zeigen/n. Zeigen | WBS Phase | WBS Discipline | WBS Type of Work | WBS Objects | IMS | UPT | TB26 Ressource Budget | Pro Unit/DocCode |
| --- | --- | --- | --- | --- | --- | --- | --- | --- | --- | --- | --- | --- | --- | --- | --- | --- | --- | --- | --- | --- | --- | --- | --- | --- | --- | --- | --- | --- | --- | --- | --- | --- | --- |
|  | 1322 | **1322 Teal Building Line 2 - CA13** |  |  | 2010-11-30 | 2011-11-24 |  |  |  |  |  |  |  |  |  |  |  |  |  |  |  |  |  |  |  |  |  |  |  |  |  |  |  |
|  | N | **N Structural Steel** |  |  | 2011-03-11 | 2011-04-20 |  |  |  |  |  |  |  |  |  |  |  |  |  |  |  |  |  |  |  |  |  |  |  |  |  |  |  |
| P3N02QE |  | CA13 Teal Bldg SK1302 - Vendor Procurement |  | 20d | 2011-03-11 A | 2011-03-30 A | EN271322 | 100% |  |  | TB26 - 2 - Manuf and Delivy |  | P3N02QE | P3N02QE | 860 | N02Q | 13 | N02Q | 200 | 200 | 400 | P | DEL | Chel | 0 | P | N | PN25 | 1322 | SS | LND |  |  |
| P3N02QL |  | CA13 Teal Bldg SK1302 - Vendor Fabrication |  | 15d | 2011-04-01 A | 2011-04-15 A | P3N02QE SS+15d, EN281322 SS+15d | 100% |  |  | TB26 - 2 - Manuf and Delivy |  | P3N02QL | P3N02QL | 860 | N02Q | 13 | N02Q | 200 | 200 | 400 | P | DEL | Chel | 0 | P | N | PN26 | 1322 | SS | LND |  |  |
| P3N02QP |  | CA13 Teal Bldg SK1302 - Transport to Site |  | 5d | 2011-04-16 A | 2011-04-20 A | P3N02QL | 100% |  |  | TB26 - 2 - Manuf and Delivy | Piperacks, Main Structures (Delivery) [5 t] | P3N02QP | P3N02QP | 860 | N02Q | 13 | N02Q | 200 | 200 | 400 | P |  | Chel | 0 | P | N | PN28 | 1322 | SS | LND | 0,00 |  |
| P3N02QN |  | CA13 Teal Bldg SK1302 - Goods arrived at Site | milestone | 0d | 2011-04-20 A | 2011-04-20 A | P3N02QP FF | 100% |  |  | TB26 - 2 - Manuf and Delivy |  | P3N02QN | P3N02QN | 860 | N02Q | 13 | N02Q | 200 | 200 | 400 | P |  | Chel | L2 | P | N | PN29 | 1322 | M | LND |  |  |
|  | H | **H HVAC** |  |  | 2011-11-24 | 2011-11-24 |  |  |  |  |  |  |  |  |  |  |  |  |  |  |  |  |  |  |  |  |  |  |  |  |  |  |  |
| P3H01SG |  | H01 HVAC Eqt. - 1stGoods arr. at Site CA13 TealB | milestone | 0d | 2011-11-24 | 2011-11-24 | P3H01P SF+240d |  | 128d | 31d | TB26 - 2 - Manuf and Delivy |  | P3H01SG | P3H01SG | 860 | H01 | 13 | H01 | 000 | 200 | 400 | P |  | SC | L2 | P | H | PH19 | 1322 | hva_as | LND |  |  |
|  | B | **B Mechanical - Stationary Equipment** |  |  | 2010-11-30 | 2011-10-13 |  |  |  |  |  |  |  |  |  |  |  |  |  |  |  |  |  |  |  |  |  |  |  |  |  |  |  |
| P3A13S2B |  | A13 Scales - Goods arr. at Site CA13 (MI-22106) | milestone | 0d | 2010-11-30 A | 2010-11-30 A | P3A13N FF | 100% |  |  | TB26 - 2 - Manuf and Delivy |  | P3A13S2B | P3A13S2B | 860 | A13 | 13 | 2DC9060 | 200 | 200 | 400 | P |  | OWN | 0 | P | B | PB99 | 1322 | S | LND |  |  |
| P3A11S2 |  | A11 Unloading Arms - Goods arrived at Site CA13 | milestone | 0d | 2011-10-13 | 2011-10-13 | P3A11N |  | 47d | 22d | TB26 - 2 - Manuf and Delivy |  | P3A11S2 | P3A11S2 | 860 | A11 | 13 | 2KB4420 | 200 | 200 | 400 | P |  | OWN | 0 | P | B | PB99 | 1322 | S | LND |  |  |
|  | M | **M Mechanical - Rotating Equipment** |  |  | 2011-03-31 | 2011-03-31 |  |  |  |  |  |  |  |  |  |  |  |  |  |  |  |  |  |  |  |  |  |  |  |  |  |  |  |
| P3M08S2B |  | M08 Teal Pump - Good arr. at Site CA13 P-22102 | milestone | 0d | 2011-03-31 A | 2011-03-31 A | P3M08N FF | 100% |  |  | TB26 - 2 - Manuf and Delivy |  | P3M08S2B | P3M08S2B | 860 | M08 | 13 | 2PA6690 | 200 | 200 | 400 | P |  | OWN | 0 | P | M | PM29 | 1322 | S | LND |  |  |
|  | 1332 | **1332 Recycle Gas Compressor - CA13** |  |  | 2008-09-06 | 2011-01-17 |  |  |  |  |  |  |  |  |  |  |  |  |  |  |  |  |  |  |  |  |  |  |  |  |  |  |  |
|  | M | **M Mechanical - Rotating Equipment** |  |  | 2008-09-06 | 2011-01-17 |  |  |  |  |  |  |  |  |  |  |  |  |  |  |  |  |  |  |  |  |  |  |  |  |  |  |  |
| EM051332 |  | CA13 R.G.Compressor - Final Loads for Civil | milestone | 0d | 2008-09-06 A | 2008-09-06 A | E3M0240 | 100% |  |  |  |  | EM051332 | EM051332 | 869 |  | 13 |  | 200 |  |  |  |  |  |  | P | M | EB05 | 1332 | I | LND |  |  |
| P3M02S2 |  | M02 Recycle Gas C. - Goods arrived at site CA13 | milestone | 0d | 2011-01-17 A | 2011-01-17 A | P3M02N3 FF, P3M02N FF | 100% |  |  | TB26 - 2 - Manuf and Delivy |  | P3M02S2 | P3M02S2 | 860 | M02 | 13 | 2DC8490 | 200 | 200 | 400 | P |  | OWN | C2 | P | M | PM19 | 1332 | S | LND |  | DC |
|  | 14 | **14 CA14 - Flare Area** |  |  | 2009-07-09 | 2011-08-14 |  |  |  |  |  |  |  |  |  |  |  |  |  |  |  |  |  |  |  |  |  |  |  |  |  |  |  |
|  | 1410 | **1410 Flare Package - CA14** |  |  | 2009-10-02 | 2011-08-14 |  |  |  |  |  |  |  |  |  |  |  |  |  |  |  |  |  |  |  |  |  |  |  |  |  |  |  |
|  | N | **N Structural Steel** |  |  | 2011-04-27 | 2011-08-14 |  |  |  |  |  |  |  |  |  |  |  |  |  |  |  |  |  |  |  |  |  |  |  |  |  |  |  |
| P3N02ЬE |  | CA14 Flare/Auxiliary Structures - Vendor Procurement |  | 35d | 2011-04-27 A | 2011-06-01 A | EN27141010 FF+22d, EN27161010 | 100% |  |  | TB26 - 2 - Manuf and Delivy |  | P3N02ЬE | P3N02ЬE | 860 | N02Ь | 14 | N02Ь | 200 | 200 | 400 | P | DEL | Chel | FL | P | N | PN25 | 1410 | SS | LND |  |  |
| PN661410 |  | CA14 Flare Package - Fabrication Gratings |  | 50d | 2011-05-12 A | 2011-06-30 A | EN641410 FF, EN681410 | 100% |  |  | TB26 - 2 - Manuf and Delivy |  | PN661410 | PN661410 | 860 | XNK | 14 |  | 200 | 200 |  | C |  |  | FL | P | N | PN66 | 1410 | SS | LND |  |  |
| P3N02ЬL |  | CA14 Flare/Auxiliary Structures - Vendor Fabrication |  | 73d | 2011-05-24 A | 2011-08-04 A | P3N02ЬE SS+20d, EN281410 SS+15d | 100% |  |  | TB26 - 2 - Manuf and Delivy |  | P3N02ЬL | P3N02ЬL | 860 | N02Ь | 14 | N02Ь | 200 | 200 | 400 | P | DEL | Chel | FL | P | N | PN26 | 1410 | SS | LND |  |  |
| PN681410 |  | CA14 Flare Package - Transport Gratings to Site |  | 10d | 2011-07-01 A | 2011-07-10 A | PN661410 | 100% |  |  | TB26 - 2 - Manuf and Delivy |  | PN681410 | PN681410 | 860 | XNK | 14 |  | 200 | 200 |  | C |  |  | FL | P | N | PN68 | 1410 | SS | LND |  |  |
| PN691410 |  | CA14 Flare Package - Gratings arrived at Site | milestone | 0d | 2011-07-10 A | 2011-07-10 A | PN681410 FF | 100% |  |  | TB26 - 2 - Manuf and Delivy |  | PN691410 | PN691410 | 860 | XNK | 14 |  | 200 | 200 |  | C |  |  | FL | P | N | PN69 | 1410 | S | LND |  |  |
| P3N02ЬP |  | CA14 Flare/Auxiliary Structures - Transport to Site |  | 10d | 2011-08-05 A | 2011-08-14 A | P3N02ЬL | 100% |  |  | TB26 - 2 - Manuf and Delivy | Piperacks, Main Structures (Delivery) [36 t]; Ladders & Platforms (Delivery) [19 t] | P3N02ЬP | P3N02ЬP | 860 | N02Ь | 14 | N02Ь | 200 | 200 | 400 | P |  | Chel | FL | P | N | PN28 | 1410 | SS | LND | 0,00 |  |
| P3N02ЬN |  | CA14 Flare/Auxiliary Structures - Goods arrived at Site | milestone | 0d | 2011-08-14 A | 2011-08-14 A | IMS-P-000080 (other project) FF, P3N02ЬP FF, P3N100 FF | 100% |  |  | TB26 - 2 - Manuf and Delivy |  | P3N02ЬN | P3N02ЬN | 860 | N02Ь | 14 | N02Ь | 200 | 200 | 400 | P |  | Chel | FL | P | N | PN29 | 1410 | M | LND |  |  |

Notes:
- P3N02QN: UDF_Actictity Name (Russia): CA12 Мешалка SK1205 - Прибытие товара на площадку
- P3H01SG: UDF_Actictity Name (Russia): H01 Оборудование ОВКВ - Прибытие 1-й партии товара на площадку, CA13 Здание ТЭА

| ID | WBS | Activity | Type | Duration | Start | Finish | Predecessors | Complete | Total float | Free float | Calendar | Resources | Cost | Actual cost | UDF_SAVE ACTID | UDF_SAVE ACT ID | Department | Type of Work | Constr. Area | Inquiry/Order No | PMT-Area | PMT-Schedule Org | PMT-Discipline | PMT-Phase | PMT-Respons. | WBS Phase | WBS Discipline | WBS Type of Work | WBS Objects | IMS | UPT | PMT-Doc. Type | Zeigen/n. Zeigen | TB26 Ressource Budget | UDF_Actictity Name (Russia) |
| --- | --- | --- | --- | --- | --- | --- | --- | --- | --- | --- | --- | --- | --- | --- | --- | --- | --- | --- | --- | --- | --- | --- | --- | --- | --- | --- | --- | --- | --- | --- | --- | --- | --- | --- | --- |
|  | B | **B Mechanical - Stationary Equipment** |  |  | 2009-10-02 | 2011-06-14 |  |  |  |  |  |  |  |  |  |  |  |  |  |  |  |  |  |  |  |  |  |  |  |  |  |  |  |  |  |
| P3A18C |  | A18 Flare Package - Eval./Negotiation |  | 151d | 2009-10-02 A | 2010-05-11 A | P3A18B, E3A1820 FF | 100% |  |  |  |  |  |  | P3A18C | P3A18C | 860 | A18 | 14 | 2DD0330 | 200 | 200 | 400 | P | LND | P | B | PB12 | 1410 | E | LND |  |  |  |  |
| P3A18F |  | A18 Flare Package - Bid tab Client appr. |  | 5d | 2009-12-22 A | 2009-12-30 A | E3A1830 | 100% |  |  |  |  |  |  | P3A18F | P3A18F | 860 | A18 | 14 | 2DD0330 | 200 | 200 | 400 | P | PMT | P | B | PB12 | 1410 | E | PMT |  |  |  |  |
| P3A18D |  | A18 Flare Package - PO issued | milestone | 0d | 2010-05-11 A | 2010-05-11 A | F2940 FF, E3A1830 FF, P3A18C FF, P3A18F FF | 100% |  |  |  |  | 436,000 | 436,000 | P3A18D | P3A18D | 860 | A18 | 14 | 2DD0330 | 200 | 200 | 400 | P | LND | P | B | PB13 | 1410 | P | LND |  |  |  |  |
| P3A18L |  | A18 Flare Package - Lead Time/Fabrication |  | 315d | 2010-05-12 A | 2011-03-25 A | P3A18D | 100% |  |  | TB26 - 2 - Manuf and Delivy |  |  |  | P3A18L | P3A18L | 860 | A18 | 14 | 2DD0330 | 200 | 200 | 400 | P | LND | P | B | PB16 | 1410 | E | LND | DEL |  |  |  |
| P3A18X |  | A18 Flare Package - Final Inspection | milestone | 0d | 2011-03-09 A | 2011-03-09 A | E3A1850 FF, P3A18L FF-17d, E3A1860 FF, ES100140 | 100% |  |  | TB26 - 2 - Manuf and Delivy |  | 654,000 | 654,000 | P3A18X | P3A18X | 860 | A18 | 14 | 2DD0330 | 200 | 200 | 400 | P | LND | P | B | PB17 | 1410 | E | LND |  |  |  |  |
| P3A18M |  | A18 Flare Package - Goods delivered FOB | milestone | 0d | 2011-03-30 A | 2011-03-30 A | P3A18X FF, P3A18L FF+5d | 100% |  |  | TB26 - 2 - Manuf and Delivy |  | 327,000 | 327,000 | P3A18M | P3A18M | 860 | A18 | 14 | 2DD0330 | 200 | 200 | 400 | P | LND | P | B | PB18 | 1410 | E | LND |  |  |  |  |
| P3A18N |  | A18 Flare Package - Transport to Site |  | 40d | 2011-05-06 A | 2011-06-14 A | P3A18M FS+35d | 100% |  |  | TB26 - 2 - Manuf and Delivy |  |  |  | P3A18N | P3A18N | 860 | A18 | 14 | 2DD0330 | 200 | 200 | 400 | P | LND | P | B | PB18 | 1410 | E | LND |  |  |  |  |
| P3A18S |  | A18 Flare Package - Goods arrived at Site CA14 | milestone | 0d | 2011-06-14 A | 2011-06-14 A | IMS-P-000070 (other project) FF, HPBA17 FF, P3A18N FF | 100% |  |  | TB26 - 2 - Manuf and Delivy |  | 218,000 | 218,000 | P3A18S | P3A18S | 860 | A18 | 14 | 2DD0330 | 200 | 200 | 400 | P | OWN | P | B | PB19 | 1410 | S | LND |  |  |  |  |
|  | 1420 | **1420 Flare Knockout Drum Section - CA14** |  |  | 2011-04-13 | 2011-08-14 |  |  |  |  |  |  |  |  |  |  |  |  |  |  |  |  |  |  |  |  |  |  |  |  |  |  |  |  |  |
|  | N | **N Structural Steel** |  |  | 2011-04-19 | 2011-08-14 |  |  |  |  |  |  |  |  |  |  |  |  |  |  |  |  |  |  |  |  |  |  |  |  |  |  |  |  |  |
| P3N02CE |  | CA14 FlareKoDrum SK1401 - Vendor Procurement |  | 35d | 2011-04-19 A | 2011-05-24 A | EN27113010 FF+22d | 100% |  |  | TB26 - 2 - Manuf and Delivy |  |  |  | P3N02CE | P3N02CE | 860 | N02C | 14 | N02C | 200 | 200 | 400 | P | Chel | P | N | PN25 | 1420 | SS | LND | DEL | 0 |  |  |
| PN661130 |  | CA14 FlareKoDrum - Fabrication Gratings |  | 80d | 2011-04-23 A | 2011-07-12 A | EN681130, EN641130 FF | 100% |  |  | TB26 - 2 - Manuf and Delivy |  |  |  | PN661130 | PN661130 | 860 | XNK | 14 |  | 200 | 200 |  | C |  | P | N | PN66 | 1420 | SS | LND |  |  |  |  |
| P3N02CL |  | CA14 FlareKoDrum SK1401 - Vendor Fabrication |  | 76d | 2011-05-21 A | 2011-08-04 A | EN281130 SS+20d, P3N02CE SS+20d | 100% |  |  | TB26 - 2 - Manuf and Delivy |  |  |  | P3N02CL | P3N02CL | 860 | N02C | 14 | N02C | 200 | 200 | 400 | P | Chel | P | N | PN26 | 1420 | SS | LND | DEL | 0 |  |  |
| PN681130 |  | CA14 FlareKoDrum - Transport Gratings to Site |  | 10d | 2011-07-13 A | 2011-07-22 A | PN661130 | 100% |  |  | TB26 - 2 - Manuf and Delivy |  |  |  | PN681130 | PN681130 | 860 | XNK | 14 |  | 200 | 200 |  | C |  | P | N | PN68 | 1420 | SS | LND |  |  |  |  |
| PN691130 |  | CA14 FlareKoDrum - Gratings arrived at Site | milestone | 0d | 2011-07-22 A | 2011-07-22 A | PN681130 FF | 100% |  |  | TB26 - 2 - Manuf and Delivy |  |  |  | PN691130 | PN691130 | 860 | XNK | 14 |  | 200 | 200 |  | C |  | P | N | PN69 | 1420 | S | LND |  |  |  |  |
| P3N02CP |  | CA14 FlareKoDrum SK1401 - Transport to Site |  | 10d | 2011-08-05 A | 2011-08-14 A | P3N02CL | 100% |  |  | TB26 - 2 - Manuf and Delivy | Ladders & Platforms (Delivery) [3 t]; Piperacks, Main Structures (Delivery) [21 t] |  |  | P3N02CP | P3N02CP | 860 | N02C | 14 | N02C | 200 | 200 | 400 | P | Chel | P | N | PN28 | 1420 | SS | LND |  | 0 | 0,00 |  |
| P3N02CN |  | CA14 FlareKoDrum SK1401 - Goods arrived at Site | milestone | 0d | 2011-08-14 A | 2011-08-14 A | P3N02CP FF, IMS-P-000090 (other project) FF | 100% |  |  | TB26 - 2 - Manuf and Delivy |  |  |  | P3N02CN | P3N02CN | 860 | N02C | 14 | N02C | 200 | 200 | 400 | P | Chel | P | N | PN29 | 1420 | M | LND |  | L2 |  | CA14 Сепаратор факела SK14... - Прибытие товара на площадку |
|  | B | **B Mechanical - Stationary Equipment** |  |  | 2011-04-13 | 2011-04-13 |  |  |  |  |  |  |  |  |  |  |  |  |  |  |  |  |  |  |  |  |  |  |  |  |  |  |  |  |  |
| P3A02AS1 |  | A02A Large Drums - Goods arr. at Site CA14 | milestone | 0d | 2011-04-13 A | 2011-04-13 A | P3A02AN FF, HPBA02A FF, IMS-P-000070 (other project) FF | 100% |  |  | TB26 - 2 - Manuf and Delivy |  |  |  | P3A02AS1 | P3A02AS1 | 860 | A02A | 14 | 2DC9450 | 200 | 200 | 400 | P | OWN | P | B | PB19 | 1420 | S | LND |  | 0 |  |  |
|  | LUZ2 | **LUZ2 General ( )** |  |  | 2009-07-09 | 2009-07-09 |  |  |  |  |  |  |  |  |  |  |  |  |  |  |  |  |  |  |  |  |  |  |  |  |  |  |  |  |  |
|  | B | **B Mechanical - Stationary Equipment** |  |  | 2009-07-09 | 2009-07-09 |  |  |  |  |  |  |  |  |  |  |  |  |  |  |  |  |  |  |  |  |  |  |  |  |  |  |  |  |  |
| P3A18E |  | A18 Flare Package - Bid Due Date | milestone | 0d | 2009-07-09 A | 2009-07-09 A | P3A18B FF+35d | 100% |  |  |  |  |  |  | P3A18E | P3A18E | 869 | A18 | 14 | 2DD0330 | 200 | 200 | 055 | E | LND | P | B | EB14 | LUZ2 | P | LND |  | 0 |  |  |
|  | 15 | **15 CA15 - Instrument Air Buffer Vessel** |  |  | 2009-02-23 | 2012-02-26 |  |  |  |  |  |  |  |  |  |  |  |  |  |  |  |  |  |  |  |  |  |  |  |  |  |  |  |  |  |
|  | 1510 | **1510 Air Buffer Vessel Section - CA15** |  |  | 2011-01-27 | 2012-02-26 |  |  |  |  |  |  |  |  |  |  |  |  |  |  |  |  |  |  |  |  |  |  |  |  |  |  |  |  |  |
|  | B | **B Mechanical - Stationary Equipment** |  |  | 2011-04-13 | 2012-02-26 |  |  |  |  |  |  |  |  |  |  |  |  |  |  |  |  |  |  |  |  |  |  |  |  |  |  |  |  |  |
| P3A02S5 |  | A02A Large Drums - Goods arrived at Site CA15 | milestone | 0d | 2011-04-13 A | 2011-04-13 A | P3A02AN FF | 100% |  |  | TB26 - 2 - Manuf and Delivy |  | 45,460 | 45,460 | P3A02S5 | P3A02S5 | 860 | A02A | 15 | 2DC9450 | 200 | 200 | 400 | P | OWN | P | B | PB19 | 1510 | S | LND |  | 0 |  |  |
| P3A02BS |  | A02B Polymer W.Bask - Goods arrived at Site CA17 | milestone | 0d | 2011-09-19 | 2011-09-19 | HPBA02B FF, P3A02BN FF, P3A02BG |  | 63d | 94.88d | TB26 - 2 - Manuf and Delivy |  | 5,758 |  | P3A02BS | P3A02BS | 860 | A02B | 17 | 2DC9840 | 200 | 200 | 400 | P | OWN | P | B | PB19 | 1710 | S | LND |  | 0 |  |  |
| P3A02DS |  | A02D Vessels Chiller Unit - Goods arrived at Site CA18 | milestone | 0d | 2012-02-05 | 2012-02-05 | P3A02DN FF |  | 486.5d |  | TB26 - 2 - Manuf and Delivy |  |  |  | P3A02S5 | P3A02DS | 860 | A02D | 18 | A02D | 200 | 200 | 400 | P | OWN | P | B | PB19 | 1810 | S | LND |  |  |  |  |
| P3M18S |  | M18 Pumps Chiller Unit - Goods arrived at Site CA18 | milestone | 0d | 2012-02-26 | 2012-02-26 | P3M18N FF |  | 465.5d |  | TB26 - 2 - Manuf and Delivy |  |  |  | P3A02S5 | P3M18S | 860 | M18 | 18 | 2PA6720 | 200 | 200 | 400 | P | OWN | P | M | PB19 | 1810 | S | LND |  |  |  |  |

Notes:
- P3A18D: Expenses: 900A 436000
- P3A18X: Expenses: 900A 654000
- P3A18M: Expenses: 900A 327000
- P3A18N: P3 Activity Log Info: per / Truck/Train
- P3A18S: Expenses: 900A 218000
- P3A02S5: Expenses: 900A 45460
- P3A02BS: Expenses: 900A 5758

| ID | WBS | Activity | Type | Duration | Start | Finish | Predecessors | Complete | Total float | Free float | Calendar | Resources | Cost | Actual cost | UDF_SAVE ACTID | UDF_SAVE ACT ID | Department | Type of Work | Constr. Area | Inquiry/Order No | PMT-Area | PMT-Schedule Org | PMT-Discipline | PMT-Phase | PMT-Respons. | Zeigen/n. Zeigen | WBS Phase | WBS Discipline | WBS Type of Work | WBS Objects | IMS | UPT | PMT-Doc. Type | TB26 Ressource Budget |
| --- | --- | --- | --- | --- | --- | --- | --- | --- | --- | --- | --- | --- | --- | --- | --- | --- | --- | --- | --- | --- | --- | --- | --- | --- | --- | --- | --- | --- | --- | --- | --- | --- | --- | --- |
|  | M | **M Mechanical - Rotating Equipment** |  |  | 2011-01-27 | 2011-10-18 |  |  |  |  |  |  |  |  |  |  |  |  |  |  |  |  |  |  |  |  |  |  |  |  |  |  |  |  |
| P3M15S1 |  | M15 Conds./BoosterP - Goods arrived at Site CA15 | milestone | 0d | 2011-01-27 A | 2011-01-27 A | P3M15G, E3M1570, P3M15N FF, HPMM15 FF | 100% |  |  | TB26 - 2 - Manuf and Delivy |  | 10,200 | 10,200 | P3M15S1 | P3M15S1 | 860 | M15 | 15 | 2PA6720 | 200 | 200 | 400 | P | OWN | 0 | P | M | PM98 | 1510 | S | LND |  |  |
| P3M14S1 |  | M14 Submers. Pumps - Goods arrived at Site CA15 | milestone | 0d | 2011-10-18 | 2011-10-18 | HPMM14 FF, P3M14N FF, P3M14G |  | 117d | 0d | TB26 - 2 - Manuf and Delivy |  | 4,900 |  | P3M14S1 | P3M14S1 | 860 | M14 | 15 | 2PA6900 | 200 | 200 | 400 | P | OWN | 0 | P | M | PM98 | 1510 | S | LND |  |  |
|  | 1511 | **1511 Sanitary Lifting Station Section - CA15** |  |  | 2009-02-23 | 2011-10-27 |  |  |  |  |  |  |  |  |  |  |  |  |  |  |  |  |  |  |  |  |  |  |  |  |  |  |  |  |
|  | E | **E Electrical** |  |  | 2009-02-23 | 2011-10-27 |  |  |  |  |  |  |  |  |  |  |  |  |  |  |  |  |  |  |  |  |  |  |  |  |  |  |  |  |
| P3E22A |  | E22 Diesel Generator - Prepare/Issue RFQ |  | 5d | 2009-02-23 A | 2009-02-27 A | E3E2210 | 100% |  |  |  |  |  |  | P3E22A | P3E22A | 87G | E22 | 15 | 2EB5450 | 200 | 200 | 400 | P | LND | 0 | P | E | EE44 | 1511 | ELE | LND | DEV |  |
| P3E22B |  | E22 Diesel Generator - RFQ issued | milestone | 0d | 2009-02-28 A | 2009-02-28 A | P3E22A FF | 100% |  |  |  |  | 16,994.05 | 16,994.05 | P3E22B | P3E22B | 87G | E22 | 15 | 2EB5450 | 200 | 200 | 400 | P | LND | 0 | P | E | EE44 | 1511 | ELE | LND | DEV |  |
| P3E22C |  | E22 Diesel Generator - Eval./Negotiation |  | 40d | 2010-02-22 A | 2010-04-20 A | P3E22B, E3E2220 FF | 100% |  |  |  |  |  |  | P3E22C | P3E22C | 87G | E22 | 15 | 2EB5450 | 200 | 200 | 400 | P | LND | 0 | P | E | EE44 | 1511 | ELE | LND |  |  |
| P3E22F |  | E22 Diesel Generator - Bid tab Client appr. |  | 5d | 2010-03-26 A | 2010-04-01 A | E3E2230 | 100% |  |  |  |  |  |  | P3E22F | P3E22F | 860 | E22 | 15 | 2EB5450 | 200 | 200 | 400 | P | PMT | 0 | P | E | EE44 | 1511 | ELE | PMT |  |  |
| P3E22D |  | E22 Diesel Generator - PO issued | milestone | 0d | 2010-04-20 A | 2010-04-20 A | F3100 FF, P3E22C FF, P3E22F FF | 100% |  |  |  |  | 84,970.25 | 84,970.25 | P3E22D | P3E22D | 87G | E22 | 15 | 2EB5450 | 200 | 200 | 400 | P | LND | 0 | P | E | EE44 | 1511 | ELE | LND |  |  |
| P3E22L |  | E22 Diesel Generator - Lead Time/Fabrication |  | 370d | 2010-04-21 A | 2011-04-29 A | P3E22D | 100% |  |  | TB26 - 2 - Manuf and Delivy |  |  |  | P3E22L | P3E22L | 87G | E22 | 15 | 2EB5450 | 200 | 200 | 400 | P | LND | 0 | P | E | EE44 | 1511 | ELE | LND | DEL |  |
| P3E22G |  | Gost R Certificate to russ. customs | milestone | 0d | 2011-01-30 A | 2011-01-30 A | P3E22N FF-90d | 100% |  |  | TB26 - 2 - Manuf and Delivy |  |  |  | P3E22G | P3E22G | 87G | E22 | 15 | 2EB5450 | 200 | 200 | 400 | P | LND | 0 | P | E | EE44 | 1511 | ELE | LND |  |  |
| P3E22X |  | E22 Diesel Generator - Final Inspection | milestone | 0d | 2011-02-28 A | 2011-02-28 A | E3E2250, P3E22L FF-12d | 100% |  |  | TB26 - 2 - Manuf and Delivy |  | 152,946.45 | 152,946.45 | P3E22X | P3E22X | 87G | E22 | 15 | 2EB5450 | 200 | 200 | 400 | P | LND | 0 | P | E | EE44 | 1511 | ELE | LND |  |  |
| P3E22M |  | E22 Diesel Generator - Goods deliv. FOB | milestone | 0d | 2011-06-04 A | 2011-06-04 A | P3E22L FF+35d, P3E22X FF | 100% |  |  | TB26 - 2 - Manuf and Delivy |  | 50,982.15 | 50,982.15 | P3E22M | P3E22M | 87G | E22 | 15 | 2EB5450 | 200 | 200 | 400 | P | LND | 0 | P | E | EE44 | 1511 | ELE | LND |  |  |
| P3E22N |  | E22 Diesel Generator - Transport to Site |  | 35d | 2011-09-23 | 2011-10-27 | P3E100 FF, P3E22M FS+110d |  | 155d | 0d | TB26 - 2 - Manuf and Delivy |  |  |  | P3E22N | P3E22N | 87G | E22 | 15 | 2EB5450 | 200 | 200 | 400 | P | LND | 0 | P | E | EE44 | 1511 | ELE | LND |  |  |
| P3E22S1 |  | E22 Diesel Generator - Goods arr. at Site CA15 | milestone | 0d | 2011-10-27 | 2011-10-27 | P3E22G, P3E22N FF, IMS-P-000130 (other project) FF |  | 155d | 183d | TB26 - 2 - Manuf and Delivy |  | 33,988 |  | P3E22S1 | P3E22S1 | 87G | E22 | 15 | 2EB5450 | 200 | 200 | 400 | P | LND | 0 | P | E | EE44 | 1511 | IT | LND |  |  |
|  | 16 | **16 CA16 - Substation / RIE's** |  |  | 2009-07-23 | 2011-11-09 |  |  |  |  |  |  |  |  |  |  |  |  |  |  |  |  |  |  |  |  |  |  |  |  |  |  |  |  |
|  | 1610 | **1610 Substation / RIE's - CA16** |  |  | 2010-09-07 | 2011-11-09 |  |  |  |  |  |  |  |  |  |  |  |  |  |  |  |  |  |  |  |  |  |  |  |  |  |  |  |  |
|  | N | **N Structural Steel** |  |  | 2010-09-07 | 2011-01-21 |  |  |  |  |  |  |  |  |  |  |  |  |  |  |  |  |  |  |  |  |  |  |  |  |  |  |  |  |
| P3N02BE |  | CA16 Subst&RIE's - Girder/Cladding - Vendor Procurement |  | 35d | 2010-09-07 A | 2010-10-11 A | EN27161010 | 100% |  |  | TB26 - 2 - Manuf and Delivy |  |  |  | P3N02BE | P3N02BE | 860 | N02B | 16 | N02B | 200 | 200 | 400 | P | Chel | 0 | P | N | PN25 | 1610 | SS | LND | DEL |  |
| P3N02BL |  | CA16 Subst&RIE's - Girder/Cladding - Vendor Fabrication |  | 77d | 2010-10-28 A | 2011-01-15 A | P3N02BE SS+25d, EN281610 SS+22d, EN641610 FF | 100% |  |  | TB26 - 2 - Manuf and Delivy |  |  |  | P3N02BL | P3N02BL | 860 | N02B | 16 | N02B | 200 | 200 | 400 | P | Chel | 0 | P | N | PN26 | 1610 | SS | LND | DEL |  |
| P3N02BP |  | CA16 Subst&RIE's - Girder/Cladding - Transport to Site |  | 5d | 2011-01-17 A | 2011-01-21 A | P3N02BL, EN681610 FF | 100% |  |  | TB26 - 2 - Manuf and Delivy | Ladders & Platforms (Delivery) [6 t]; Piperacks, Main Structures (Delivery) [90 t] |  |  | P3N02BP | P3N02BP | 860 | N02B | 16 | N02B | 200 | 200 | 400 | P | Chel | 0 | P | N | PN28 | 1610 | SS | LND |  | 0,00 |
| P3N02BN |  | CA16 Subst&RIE's - Girder/Cladding - Goods arrived at Site | milestone | 0d | 2011-01-21 A | 2011-01-21 A | P3N02BP FF | 100% |  |  | TB26 - 2 - Manuf and Delivy |  |  |  | P3N02BN | P3N02BN | 860 | N02B | 16 | N02B | 200 | 200 | 400 | P | Chel | L2 | P | N | PN29 | 1610 | M | LND |  |  |
|  | H | **H HVAC** |  |  | 2011-04-17 | 2011-04-17 |  |  |  |  |  |  |  |  |  |  |  |  |  |  |  |  |  |  |  |  |  |  |  |  |  |  |  |  |
| P3H01SA |  | H01 HVAC Eqt. - 1stGoods arr. at Site CA16 Subst | milestone | 0d | 2011-04-17 A | 2011-04-17 A | P3H01P SF+20d | 100% |  |  | TB26 - 2 - Manuf and Delivy |  |  |  | P3H01SA | P3H01SA | 860 | H01 | 16 | H01 | 000 | 200 | 400 | P | SC | L2 | P | H | PH19 | 1610 | hva_as | LND |  |  |

Notes:
- P3M15S1: Expenses: 900A 10200
- P3M14S1: Expenses: 900A 4900
- P3E22B: Expenses: 900A 16994
- P3E22D: Expenses: 900A 84970.2
- P3E22X: Expenses: 900A 152946
- P3E22M: Expenses: 900A 50982.2
- P3E22S1: Expenses: 900A 33988
- P3N02BN: UDF_Actictity Name (Russia): CA15 Буферная емкость воздуха SK1501 - Прибытие товара на площадку
- P3H01SA: UDF_Actictity Name (Russia): H01 Оборудование ОВКВ - Прибытие 1-й партии товара на площадку, CA16 Подстанция

| ID | WBS | Activity | Type | Duration | Start | Finish | Predecessors | Complete | Remaining | Total float | Free float | Constraint | Expected finish | Calendar | Cost | Actual cost | UDF_SAVE ACTID | UDF_SAVE ACT ID | Department | Type of Work | Constr. Area | Inquiry/Order No | PMT-Area | PMT-Schedule Org | PMT-Discipline | PMT-Phase | PMT-Respons. | Zeigen/n. Zeigen | WBS Phase | WBS Discipline | WBS Type of Work | WBS Objects | IMS | UPT | PMT-Doc. Type |
| --- | --- | --- | --- | --- | --- | --- | --- | --- | --- | --- | --- | --- | --- | --- | --- | --- | --- | --- | --- | --- | --- | --- | --- | --- | --- | --- | --- | --- | --- | --- | --- | --- | --- | --- | --- |
|  | E | **E Electrical** |  |  | 2010-12-04 | 2011-11-09 |  |  |  |  |  |  |  |  |  |  |  |  |  |  |  |  |  |  |  |  |  |  |  |  |  |  |  |  |  |
| P3E02S1 |  | E02 PowerTransformer - Goods arr. at SiteCA16 | milestone | 0d | 2010-12-04 A | 2010-12-04 A | P3E02N FF, HPEE02 FF, P3E02G | 100% |  |  |  |  |  | TB26 - 2 - Manuf and Delivy | 99,000 | 99,000 | P3E02S1 | P3E02S1 | 860 | E02 | 16 | 2EB5620 | 200 | 200 | 400 | P | OWN | 0 | P | E | EE20 | 1610 | ELE | LND |  |
| P3E07S1 |  | E07 UPS/DC-System - Goods arriv. at Site CA16 | milestone | 0d | 2011-05-25 A | 2011-05-25 A | P3E07G, P3E07N FF | 100% |  |  |  |  |  | TB26 - 2 - Manuf and Delivy | 66,159 | 66,159 | P3E07S1 | P3E07S1 | 860 | E07 | 16 | 2EB5610 | 200 | 200 | 400 | P | OWN | 0 | P | E | EE24 | 1610 | IT | LND |  |
| P3E01BS1 |  | E01B LV-SWG/MCC/Softstarter/FQ - Goods arr. at SiteCA16 | milestone | 0d | 2011-06-25 A | 2011-06-25 A | HPEE01B FF, P3E01BN FF, P3E01BG | 100% |  |  |  |  |  | TB26 - 2 - Manuf and Delivy |  |  | P3E01BS1 | P3E01BS1 | 860 | E01B | 16 | 2EB5630 | 200 | 200 | 400 | P | OWN | 0 | P | E | EE20 | 1610 | ELE | LND |  |
| P3E13S |  | E13 CCTV System - Goods arrivived at Site | milestone | 0d | 2011-11-09 | 2011-11-09 | P3E13N FF, HPEE13 FF, P3E100 FF |  |  | 438.5d | 164d |  |  | TB26 - 2 - Manuf and Delivy |  |  | P3E13S | P3E13S | 860 | E13 | 16 | 2EB6080 | 200 | 200 | 400 | P | OWN | 0 | P | E | EE24 | 1610 | IT | LND |  |
|  | J | **J Instrumentation** |  |  | 2011-07-15 | 2011-08-16 |  |  |  |  |  |  |  |  |  |  |  |  |  |  |  |  |  |  |  |  |  |  |  |  |  |  |  |  |  |
| P3J06S1 |  | J06 DCS / SIS - Goods arr.at Site CA16 | milestone | 0d | 2011-07-15 A | 2011-07-15 A | P3J06N FF, IMS-P-000170 (other project) FF | 100% |  |  |  |  |  | TB26 - 2 - Manuf and Delivy | 672,000 | 672,000 | P3J06S1 | P3J06S1 | 860 | J06 | 16 | 2JD9220 | 200 | 200 | 400 | P | LND | 0 | P | J | PJ29 | 1610 | INS | LND |  |
| P3J06AS |  | J06A Power Supp Cab.- Goods arr.at Site CA16 | milestone | 0d | 2011-08-16 A | 2011-08-16 A | IMS-P-000170 (other project) FF, HPJJ06A FF, P3J06AN FF, P3J06AG | 100% |  |  |  |  |  | TB26 - 2 - Manuf and Delivy | 14,298 | 14,298 | P3J06AS | P3J06AS | 860 | J06A | 16 | 2JD9640 | 200 | 200 | 400 | P | OWN | 0 | P | J | PJ29 | 1610 | IT | LND |  |
| P3J06CS1 |  | J06B Interface/Special Dev. Cabinets (E+I)-Goods arr.at Site CA16 | milestone | 0d | 2011-08-16 A | 2011-08-16 A | HPJJ06B FF, P3J06BG, P3J06BN FF, IMS-P-000170 (other project) FF | 100% |  |  |  |  |  | TB26 - 2 - Manuf and Delivy | 28,702 | 28,702 | P3J06CS1 | P3J06CS1 | 860 | J06B | 16 | 2JD9640 | 200 | 200 | 400 | P | OWN | 0 | P | J | PJ29 | 1610 | IT | LND |  |
|  | LUZ2 | **LUZ2 General ( )** |  |  | 2009-07-23 | 2011-11-09 |  |  |  |  |  |  |  |  |  |  |  |  |  |  |  |  |  |  |  |  |  |  |  |  |  |  |  |  |  |
|  | E | **E Electrical** |  |  | 2009-07-23 | 2011-11-09 |  |  |  |  |  |  |  |  |  |  |  |  |  |  |  |  |  |  |  |  |  |  |  |  |  |  |  |  |  |
| P3E02A |  | E02 PowerTransformer - Prepare/Issue RFQ |  | 3d | 2009-07-23 A | 2009-07-27 A | E03E0210 | 100% |  |  |  |  |  |  |  |  | P3E02A | P3E02A | 860 | E02 | 16 | 2EB5620 | 200 | 200 | 400 | P | LND | 0 | P | E | EE20 | LUZ2 | ELE | LND | DEV |
| P3E07A |  | E07 UPS/DC-System - Prepare/Issue RFQ |  | 3d | 2009-07-23 A | 2009-07-27 A | E3E0710 | 100% |  |  |  |  |  |  |  |  | P3E07A | P3E07A | 860 | E07 | 16 | 2EB5610 | 200 | 200 | 400 | P | LND | 0 | P | E | EE24 | LUZ2 | ELE | LND | DEV |
| P3E01AA |  | E01A MV-SWG/MCC - Prepare/Issue RFQ |  | 3d | 2009-07-27 A | 2009-07-29 A | E3E01A10 | 100% |  |  |  |  |  |  |  |  | P3E01AA | P3E01AA | 860 | E01A | 16 | 2EB5640 | 200 | 200 | 400 | P | LND | 0 | P | E | EE20 | LUZ2 | E | LND | DEV |
| P3E01BA |  | E01B LV-SWG/MCC/Softstarter/FQ - Prepare/Issue RFQ |  | 3d | 2009-07-27 A | 2009-07-29 A | E3E01B10 | 100% |  |  |  |  |  |  |  |  | P3E01BA | P3E01BA | 860 | E01B | 16 | 2EB5630 | 200 | 200 | 400 | P | LND | 0 | P | E | EE20 | LUZ2 | ELE | LND | DEV |
| P3E02B |  | E02 PowerTransformer - RFQ issued | milestone | 0d | 2009-07-27 A | 2009-07-27 A | P3E02A FF | 100% |  |  |  |  |  |  | 49,500 | 49,500 | P3E02B | P3E02B | 860 | E02 | 16 | 2EB5620 | 200 | 200 | 400 | P | LND | 0 | P | E | EE20 | LUZ2 | ELE | LND | DEV |
| P3E07B |  | E07 UPS/DC-System - RFQ issued | milestone | 0d | 2009-07-27 A | 2009-07-27 A | P3E07A FF | 100% |  |  |  |  |  |  | 33,079.35 | 33,079.35 | P3E07B | P3E07B | 860 | E07 | 16 | 2EB5610 | 200 | 200 | 400 | P | LND | 0 | P | E | EE24 | LUZ2 | ELE | LND | DEV |
| P3E01AB |  | E01A MV-SWG/MCC - RFQ issued | milestone | 0d | 2009-07-29 A | 2009-07-29 A | P3E01AA FF | 100% |  |  |  |  |  |  | 58,295 | 58,295 | P3E01AB | P3E01AB | 860 | E01A | 16 | 2EB5640 | 200 | 200 | 400 | P | LND | 0 | P | E | EE20 | LUZ2 | E | LND | DEV |
| P3E01BB |  | E01B LV-SWG/MCC/Softstarter/FQ - RFQ issued | milestone | 0d | 2009-07-29 A | 2009-07-29 A | P3E01BA FF | 100% |  |  |  |  |  |  | 273,772.65 | 273,772.65 | P3E01BB | P3E01BB | 860 | E01B | 16 | 2EB5630 | 200 | 200 | 400 | P | LND | 0 | P | E | EE20 | LUZ2 | ELE | LND | DEV |
| IMS-E-000060 |  | VD Review (Rotating, Stationary, PU's) | level of effort | 242d | 2009-10-05 A | 2010-09-20 A | E3U1540 | 100% |  |  |  |  |  |  |  |  | IMS-E-000060 | IMS-E-000060 | 860 |  | 16 |  | 200 | 200 | 400 | P | LND | 0 | P | E | EE24 | LUZ2 | 3 | IMS |  |
| P3E02C |  | E02 PowerTransformer - Eval./Negotiation |  | 53d | 2009-12-10 A | 2010-02-26 A | E3E0220 FF, P3E02B | 100% |  |  |  |  |  |  |  |  | P3E02C | P3E02C | 860 | E02 | 16 | 2EB5620 | 200 | 200 | 400 | P | LND | 0 | P | E | EE20 | LUZ2 | ELE | LND |  |
| P3E01AC |  | E01A MV-SWG/MCC - Eval./Negotiation |  | 51d | 2009-12-14 A | 2010-02-26 A | P3E01AB, E3E01A20 FF | 100% |  |  |  |  |  |  |  |  | P3E01AC | P3E01AC | 860 | E01A | 16 | 2EB5640 | 200 | 200 | 400 | P | LND | 0 | P | E | EE20 | LUZ2 | ELE | LND |  |
| P3E01BC |  | E01B LV-SWG/MCC/Softstarter/FQ - Eval./Negotiation |  | 47d | 2009-12-18 A | 2010-02-26 A | P3E01BB, E3E01B20 FF | 100% |  |  |  |  |  |  |  |  | P3E01BC | P3E01BC | 860 | E01B | 16 | 2EB5630 | 200 | 200 | 400 | P | LND | 0 | P | E | EE20 | LUZ2 | ELE | LND |  |
| P3E07C |  | E07 UPS/DC-System - Eval./Negotiation |  | 50d | 2010-02-16 A | 2010-04-28 A | P3E07B, E3E0720 FF | 100% |  |  |  |  |  |  |  |  | P3E07C | P3E07C | 860 | E07 | 16 | 2EB5610 | 200 | 200 | 400 | P | LND | 0 | P | E | EE24 | LUZ2 | ELE | LND |  |
| P3E01AD |  | E01A MV-SWG/MCC - PO issued | milestone | 0d | 2010-02-26 A | 2010-02-26 A | P3E01AF FF, E3E01A30 FF, P3E01AC FF | 100% |  |  |  |  |  |  | 291,475 | 291,475 | P3E01AD | P3E01AD | 860 | E01A | 16 | 2EB5640 | 200 | 200 | 400 | P | LND | 0 | P | E | EE20 | LUZ2 | ELE | LND |  |
| P3E01BD |  | E01B LV-SWG/MCC/Softstarter/FQ - PO issued | milestone | 0d | 2010-02-26 A | 2010-02-26 A | P3E01BC FF, P3E01BF FF, E3E01B30 FF | 100% |  |  |  |  |  |  | 1,368,863.25 | 1,368,863.25 | P3E01BD | P3E01BD | 860 | E01B | 16 | 2EB5630 | 200 | 200 | 400 | P | LND | 0 | P | E | EE20 | LUZ2 | ELE | LND |  |
| P3E02D |  | E02 PowerTransformer - PO issued | milestone | 0d | 2010-02-26 A | 2010-02-26 A | P3E02F FF, E3E0230 FF, P3E02C FF | 100% |  |  |  |  |  |  | 247,500 | 247,500 | P3E02D | P3E02D | 860 | E02 | 16 | 2EB5620 | 200 | 200 | 400 | P | LND | 0 | P | E | EE20 | LUZ2 | ELE | LND |  |
| P3E01AL |  | E01A MV-SWG/MCC - Lead Time/Fabrication |  | 215d | 2010-02-27 A | 2010-09-30 A | P3E01AD | 100% |  |  |  |  |  | TB26 - 2 - Manuf and Delivy |  |  | P3E01AL | P3E01AL | 860 | E01A | 16 | 2EB5640 | 200 | 200 | 400 | P | LND | 0 | P | E | EE20 | LUZ2 | ELE | LND | DEL |
| P3E01BL |  | E01B LV-SWG/MCC/Softstarter/FQ - Lead Time/Fabrication |  | 335d | 2010-02-27 A | 2011-01-31 A | P3E01BD | 100% |  |  |  |  |  | TB26 - 2 - Manuf and Delivy |  |  | P3E01BL | P3E01BL | 860 | E01B | 16 | 2EB5630 | 200 | 200 | 400 | P | LND | 0 | P | E | EE20 | LUZ2 | ELE | LND | DEL |
| P3E02L |  | E02 PowerTransformer - Lead Time/Fabrication |  | 205d | 2010-02-27 A | 2010-09-20 A | P3E02D | 100% |  |  |  |  |  | TB26 - 2 - Manuf and Delivy |  |  | P3E02L | P3E02L | 860 | E02 | 16 | 2EB5620 | 200 | 200 | 400 | P | LND | 0 | P | E | EE20 | LUZ2 | ELE | LND | DEL |
| IMS-E-000200 |  | Vendor Data Review Main Electrical Equipment | level of effort | 161d | 2010-03-29 A | 2010-11-12 A | E3E01A50 SS, E3E0250 SF | 100% |  |  |  |  |  |  |  |  | IMS-E-000200 | IMS-E-000200 | 860 |  | 16 |  | 200 | 200 | 400 | P | LND | 0 | P | E | EE24 | LUZ2 | P | IMS |  |
| P3E07D |  | E07 UPS/DC-System - PO issued | milestone | 0d | 2010-04-28 A | 2010-04-28 A | P3E07F, P3E07C FF, E3E0730 FF | 100% |  |  |  |  |  |  | 165,396.75 | 165,396.75 | P3E07D | P3E07D | 860 | E07 | 16 | 2EB5610 | 200 | 200 | 400 | P | LND | 0 | P | E | EE24 | LUZ2 | ELE | LND |  |
| P3E07L |  | E07 UPS/DC-System - Lead Time/Fabrication |  | 266d | 2010-04-29 A | 2011-01-23 A | P3E07D | 100% |  |  |  |  |  | TB26 - 2 - Manuf and Delivy |  |  | P3E07L | P3E07L | 860 | E07 | 16 | 2EB5610 | 200 | 200 | 400 | P | LND | 0 | P | E | EE24 | LUZ2 | ELE | LND | DEL |
| P3E01AG |  | E01A Gost R Certificate to russ. customs | milestone | 0d | 2010-07-13 A | 2010-07-13 A | P3E01AN FF-100d | 100% |  |  |  |  |  | TB26 - 2 - Manuf and Delivy |  |  | P3E01AG | P3E01AG | 860 | E01A | 16 | 2EB5640 | 200 | 200 | 400 | P | LND | 0 | P | E | EE20 | LUZ2 | ELE | LND |  |
| P3E02G |  | Gost R Certificate to russ. customs | milestone | 0d | 2010-07-23 A | 2010-07-23 A | P3E02N FF-90d | 100% |  |  |  |  |  | TB26 - 2 - Manuf and Delivy |  |  | P3E02G | P3E02G | 860 | E02 | 16 | 2EB5620 | 200 | 200 | 400 | P | LND | 0 | P | E | EE20 | LUZ2 | ELE | LND |  |
| P3E07G |  | E07- Gost R Certificate to russ. customs | milestone | 0d | 2010-07-23 A | 2010-07-23 A | P3E07N FF-90d, P3E13N FF-90d | 100% |  |  |  |  |  | TB26 - 2 - Manuf and Delivy |  |  | P3E07G | P3E07G | 860 | E07 | 16 | 2EB5610 | 200 | 200 | 400 | P | LND | 0 | P | E | EE24 | LUZ2 | ELE | LND |  |
| P3E02X |  | E02 PowerTransformer - Final Inspection | milestone | 0d | 2010-08-25 A | 2010-08-25 A | P3E02L FF-7d, E3E0250 | 100% |  |  |  |  |  | TB26 - 2 - Manuf and Delivy | 445,500 | 445,500 | P3E02X | P3E02X | 860 | E02 | 16 | 2EB5620 | 200 | 200 | 400 | P | LND | 0 | P | E | EE20 | LUZ2 | ELE | LND |  |
| P3E01AX |  | E01A MV-SWG/MCC - Final Inspection | milestone | 0d | 2010-08-30 A | 2010-08-30 A | E3E01A50, P3E01AL FF-2d | 100% |  |  |  |  |  | TB26 - 2 - Manuf and Delivy | 524,655 | 524,655 | P3E01AX | P3E01AX | 860 | E01A | 16 | 2EB5640 | 200 | 200 | 400 | P | LND | 0 | P | E | EE20 | LUZ2 | ELE | LND |  |
| P3E07X |  | E07 UPS/DC-System - Final Inspection | milestone | 0d | 2010-09-15 A | 2010-09-15 A | P3E07L FF-5d | 100% |  |  |  |  |  | TB26 - 2 - Manuf and Delivy | 297,714.15 | 297,714.15 | P3E07X | P3E07X | 860 | E07 | 16 | 2EB5610 | 200 | 200 | 400 | P | LND | 0 | P | E | EE24 | LUZ2 | ELE | LND |  |
| P3E01AM |  | E01A MV-SWG/MCC - Goods deliv. FOB | milestone | 0d | 2010-09-30 A | 2010-09-30 A | P3E01AL FF+10d, P3E01AX FF | 100% |  |  |  |  |  | TB26 - 2 - Manuf and Delivy | 174,885 | 174,885 | P3E01AM | P3E01AM | 860 | E01A | 16 | 2EB5640 | 200 | 200 | 400 | P | LND | 0 | P | E | EE20 | LUZ2 | ELE | LND |  |
| P3E02M |  | E02 PowerTransformer - Goods deliv. FOB | milestone | 0d | 2010-09-30 A | 2010-09-30 A | P3E02L FF+10d, P3E02X FF | 100% |  |  |  |  |  | TB26 - 2 - Manuf and Delivy | 148,500 | 148,500 | P3E02M | P3E02M | 860 | E02 | 16 | 2EB5620 | 200 | 200 | 400 | P | LND | 0 | P | E | EE20 | LUZ2 | ELE | LND |  |
| P3E02N |  | E02 PowerTransformer - Transport to Site depends on prov. TSF Area (heated) |  | 20d | 2010-11-15 A | 2010-12-04 A | P3E02M | 100% |  |  |  |  |  | TB26 - 2 - Manuf and Delivy |  |  | P3E02N | P3E02N | 860 | E02 | 16 | 2EB5620 | 200 | 200 | 400 | P | LND | 0 | P | E | EE20 | LUZ2 | ELE | LND |  |
| P3E01AN |  | E01A MV-SWG/MCC - Transport to Site |  | 17d | 2010-11-25 A | 2010-12-11 A | P3E01AM | 100% |  |  |  |  |  | TB26 - 2 - Manuf and Delivy |  |  | P3E01AN | P3E01AN | 860 | E01A | 16 | 2EB5640 | 200 | 200 | 400 | P | LND | 0 | P | E | EE20 | LUZ2 | ELE | LND |  |
| P3E01BG |  | Gost R Certificate to russ. customs | milestone | 0d | 2010-12-20 A | 2010-12-20 A | P3E01BN FF-100d | 100% |  |  |  |  |  | TB26 - 2 - Manuf and Delivy |  |  | P3E01BG | P3E01BG | 860 | E01B | 16 | 2EB5630 | 200 | 200 | 400 | P | LND | 0 | P | E | EE20 | LUZ2 | ELE | LND |  |
| P3E01BX |  | E01B LV-SWG/MCC/Softstarter/FQ - Final Inspection | milestone | 0d | 2011-01-21 A | 2011-01-21 A | E3E01B50, P3E01BL FF-11d | 100% |  |  |  |  |  | TB26 - 2 - Manuf and Delivy | 2,463,953.85 | 2,463,953.85 | P3E01BX | P3E01BX | 860 | E01B | 16 | 2EB5630 | 200 | 200 | 400 | P | LND | 0 | P | E | EE20 | LUZ2 | ELE | LND |  |
| P3E07M |  | E07 UPS/DC-System - Goods deliv. FOB | milestone | 0d | 2011-01-28 A | 2011-01-28 A | P3E07L FF+5d, P3E07X FF, E3E0750 | 100% |  |  |  |  |  | TB26 - 2 - Manuf and Delivy | 99,238.05 | 99,238.05 | P3E07M | P3E07M | 860 | E07 | 16 | 2EB5610 | 200 | 200 | 400 | P | LND | 0 | P | E | EE24 | LUZ2 | ELE | LND |  |
| P3E01BM |  | E01B LV-SWG/MCC/Softstarter/FQ - Goods deliv. FCA/FOB | milestone | 0d | 2011-01-31 A | 2011-01-31 A | P3E01BX FF, P3E01BL FF | 100% |  |  |  |  |  | TB26 - 2 - Manuf and Delivy | 821,317.95 | 821,317.95 | P3E01BM | P3E01BM | 860 | E01B | 16 | 2EB5630 | 200 | 200 | 400 | P | LND | 0 | P | E | EE20 | LUZ2 | ELE | LND |  |
| P3E07N |  | E07 UPS/DC-System - Transport to Site (depends since Feb on PMT approval) |  | 35d | 2011-04-20 A | 2011-05-25 A | P3E07M | 100% |  |  |  | start on 2011-04-20 |  | TB26 - 2 - Manuf and Delivy |  |  | P3E07N | P3E07N | 860 | E07 | 16 | 2EB5610 | 200 | 200 | 400 | P | LND | 0 | P | E | EE24 | LUZ2 | ELE | LND |  |
| P3E01BN |  | E01B LV-SWG/MCC/Softstarter/FQ - Transport to Site depends on heated supply possibilities |  | 20d | 2011-06-06 A | 2011-06-25 A | P3E01BM FS+10d | 100% |  |  |  |  |  | TB26 - 2 - Manuf and Delivy |  |  | P3E01BN | P3E01BN | 860 | E01B | 16 | 2EB5630 | 200 | 200 | 400 | P | LND | 0 | P | E | EE20 | LUZ2 | ELE | LND |  |
| P3E13D |  | E13 CCTV System - PO issued | milestone | 0d | 2011-06-23 A | 2011-06-23 A | P3E13C FF | 100% |  |  |  |  |  |  |  |  | P3E13D | P3E13D | 860 | E13 | 16 | 2EB6080 | 200 | 200 | 400 | P | UIO | 0 | P | E | EE24 | LUZ2 | ELE | LND |  |
| P3E13L |  | E13 CCTV System - Lead Time/Fabrication |  | 99d | 2011-06-24 A | 2011-09-30 | P3E13D |  | 30d | 438.5d | 0d |  | 2011-09-30 | TB26 - 2 - Manuf and Delivy |  |  | P3E13L | P3E13L | 860 | E13 | 16 | 2EB6080 | 200 | 200 | 400 | P | UIO | 0 | P | E | EE24 | LUZ2 | ELE | LND | DEL |
| P3E13X |  | E13 CCTV System - Final Inspection | milestone | 0d | 2011-09-26 | 2011-09-26 | P3E13L FF-5d |  |  | 448.5d | 10d |  |  | TB26 - 2 - Manuf and Delivy |  |  | P3E13X | P3E13X | 860 | E13 | 16 | 2EB6080 | 200 | 200 | 400 | P | UIO | 0 | P | E | EE24 | LUZ2 | ELE | LND |  |
| P3E13M |  | E13 CCTV System - Goods deliv. FOB | milestone | 0d | 2011-10-05 | 2011-10-05 | P3E13X FF, E3E1350, P3E13L FF+5d |  |  | 438.5d | 0d |  |  | TB26 - 2 - Manuf and Delivy |  |  | P3E13M | P3E13M | 860 | E13 | 16 | 2EB6080 | 200 | 200 | 400 | P | UIO | 0 | P | E | EE24 | LUZ2 | ELE | LND |  |
| P3E13N |  | E13 CCTV System - Transport to Site |  | 35d | 2011-10-06 | 2011-11-09 | P3E13M |  |  | 438.5d | 0d |  |  | TB26 - 2 - Manuf and Delivy |  |  | P3E13N | P3E13N | 860 | E13 | 16 | 2EB6080 | 200 | 200 | 400 | P | UIO | 0 | P | E | EE24 | LUZ2 | ELE | LND |  |

Notes:
- P3E02S1: Expenses: 900A 99000
- P3E07S1: Expenses: 900A 66159
- P3J06S1: Expenses: 900A 672000
- P3J06AS: Expenses: 900A 14298
- P3J06CS1: Expenses: 900A 28702
- P3E02B: Expenses: 900A 49500
- P3E07B: Expenses: 900A 33079.3
- P3E01AB: Expenses: 900A 58295
- P3E01BB: Expenses: 900A 273773
- P3E01AD: Expenses: 900A 291475
- P3E01BD: Expenses: 900A 1368863
- P3E02D: Expenses: 900A 247500
- P3E07D: Expenses: 900A 165397
- P3E02X: Expenses: 900A 445500
- P3E01AX: Expenses: 900A 524655
- P3E07X: Expenses: 900A 297714
- P3E01AM: Expenses: 900A 174885
- P3E02M: Expenses: 900A 148500
- P3E01BX: Expenses: 900A 2463954
- P3E07M: Expenses: 900A 99238.1
- P3E01BM: Expenses: 900A 821318

| ID | WBS | Activity | Type | Duration | Start | Finish | Predecessors | Complete | Calendar | Resources | UDF_SAVE ACTID | UDF_SAVE ACT ID | Department | Type of Work | Constr. Area | Pro Unit/DocCode | Inquiry/Order No | PMT-Area | PMT-Schedule Org | PMT-Discipline | PMT-Phase | PMT-Respons. | Zeigen/n. Zeigen | WBS Phase | WBS Discipline | WBS Type of Work | WBS Objects | IMS | UPT | PMT-Doc. Type | TB26 Ressource Budget |
| --- | --- | --- | --- | --- | --- | --- | --- | --- | --- | --- | --- | --- | --- | --- | --- | --- | --- | --- | --- | --- | --- | --- | --- | --- | --- | --- | --- | --- | --- | --- | --- |
|  | J | **J Instrumentation** |  |  | 2009-12-16 | 2009-12-16 |  |  |  |  |  |  |  |  |  |  |  |  |  |  |  |  |  |  |  |  |  |  |  |  |  |
| P3J06B1 |  | J06 DCS / SIS - RFQ issued to Yokogawa | milestone | 0d | 2009-12-16 A | 2009-12-16 A | E3J0614 FS+3d | 100% |  |  | P3J06B1 | P3J06B1 | 86C | J06 | 16 | 999 | 2JD9220 | 200 | 200 | 055 | E | LND | 0 | P | J | EJ24 | LUZ2 | INS | LND |  |  |
|  | 17 | **17 CA17 - Extruder Pack / Additive Handling-Line1/2** |  |  | 2008-04-26 | 2012-02-25 |  |  |  |  |  |  |  |  |  |  |  |  |  |  |  |  |  |  |  |  |  |  |  |  |  |
|  | 1701 | **1701 Auxiliary/Monorail/Crane Structures - CA17** |  |  | 2011-02-11 | 2011-04-17 |  |  |  |  |  |  |  |  |  |  |  |  |  |  |  |  |  |  |  |  |  |  |  |  |  |
|  | N | **N Structural Steel** |  |  | 2011-02-11 | 2011-04-17 |  |  |  |  |  |  |  |  |  |  |  |  |  |  |  |  |  |  |  |  |  |  |  |  |  |
| P3N02ME |  | CA17 Monorail/Crane ins. Extr.Room - Vendor Procurement |  | 25d | 2011-02-11 A | 2011-03-07 A | EN27170110 | 100% | TB26 - 2 - Manuf and Delivy |  | P3N02ME | P3N02ME | 860 | N02M | 17 |  | N02M | 200 | 200 | 400 | P | Chel | 0 | P | N | PN25 | 1701 | SS | LND | DEL |  |
| P3N02ML |  | CA17 Monorail/Crane ins. Extr.Room - Vendor Fabrication |  | 40d | 2011-03-04 A | 2011-04-12 A | P3N02ME SS+10d, EN281701 SS+15d | 100% | TB26 - 2 - Manuf and Delivy |  | P3N02ML | P3N02ML | 860 | N02M | 17 |  | N02M | 200 | 200 | 400 | P | Chel | 0 | P | N | PN26 | 1701 | SS | LND | DEL |  |
| P3N02MP |  | CA17 Monorail/Crane ins. Extr.Room - Transport to Site |  | 5d | 2011-04-13 A | 2011-04-17 A | P3N02ML | 100% | TB26 - 2 - Manuf and Delivy |  | P3N02MP | P3N02MP | 860 | N02M | 17 |  | N02M | 200 | 200 | 400 | P | Chel | 0 | P | N | PN28 | 1701 | SS | LND |  |  |
| P3N02MN |  | CA17 Monorail/Crane ins. Extr.Room - Goods arrived at Site | milestone | 0d | 2011-04-17 A | 2011-04-17 A | P3N02MP FF | 100% | TB26 - 2 - Manuf and Delivy |  | P3N02MN | P3N02MN | 860 | N02M | 17 |  | N02M | 200 | 200 | 400 | P | Chel | L2 | P | N | PN29 | 1701 | M | LND |  |  |
|  | 1704 | **1704 Internal Pipe Racks - CA17** |  |  | 2011-02-22 | 2011-05-29 |  |  |  |  |  |  |  |  |  |  |  |  |  |  |  |  |  |  |  |  |  |  |  |  |  |
|  | N | **N Structural Steel** |  |  | 2011-02-22 | 2011-05-29 |  |  |  |  |  |  |  |  |  |  |  |  |  |  |  |  |  |  |  |  |  |  |  |  |  |
| P3N02UE |  | CA17 SK1704 PR i. Extr.B - Vendor Procurement |  | 37d | 2011-02-22 A | 2011-03-30 A | EN27170410 | 100% | TB26 - 2 - Manuf and Delivy |  | P3N02UE | P3N02UE | 860 | N02U | 17 |  | N02U | 200 | 200 | 400 | P | Chel | 0 | P | N | PN25 | 1704 | SS | LND | DEL |  |
| P3N02OE |  | CA17 SK1705/09 Platforms - Vendor Procurement |  | 30d | 2011-03-19 A | 2011-04-17 A | EN27170510 | 100% | TB26 - 2 - Manuf and Delivy |  | P3N02OE | P3N02OE | 860 | N02O | 17 |  | N02O | 200 | 200 | 400 | P | Chel | 0 | P | N | PN25 | 1704 | SS | LND | DEL |  |
| P3N02UL |  | CA17 SK1704 PR i. Extr.B - Vendor Fabrication |  | 50d | 2011-03-22 A | 2011-05-11 A | EN281704 SS+20d, P3N02UE SS+20d | 100% | TB26 - 2 - Manuf and Delivy |  | P3N02UL | P3N02UL | 860 | N02U | 17 |  | N02U | 200 | 200 | 400 | P | Chel | 0 | P | N | PN26 | 1704 | SS | LND | DEL |  |
| P3N02OL |  | CA17 SK1705/09 Platforms - Vendor Fabrication |  | 40d | 2011-04-09 A | 2011-05-19 A | P3N02OE SS+20d, EN281705 SS+15d | 100% | TB26 - 2 - Manuf and Delivy |  | P3N02OL | P3N02OL | 860 | N02O | 17 |  | N02O | 200 | 200 | 400 | P | Chel | 0 | P | N | PN26 | 1704 | SS | LND | DEL |  |
| P3N02UP |  | CA17 SK1704 PR i. Extr.B - Transport to Site |  | 10d | 2011-05-12 A | 2011-05-21 A | P3N02UL | 100% | TB26 - 2 - Manuf and Delivy | Piperacks, Main Structures (Delivery) [189 t] | P3N02UP | P3N02UP | 860 | N02U | 17 |  | N02U | 200 | 200 | 400 | P | Chel | 0 | P | N | PN28 | 1704 | SS | LND |  | 0,00 |
| P3N02OP |  | CA17 SK1705/09 Platforms - Transport to Site |  | 10d | 2011-05-20 A | 2011-05-29 A | P3N02OL | 100% | TB26 - 2 - Manuf and Delivy | Ladders & Platforms (Delivery) [257 t] | P3N02OP | P3N02OP | 860 | N02O | 17 |  | N02O | 200 | 200 | 400 | P | Chel | 0 | P | N | PN28 | 1704 | SS | LND |  | 0,00 |
| P3N02UN |  | CA17 SK1704 PR i. Extr.B - Goods arrived at Site (1st parts) | milestone | 0d | 2011-05-21 A | 2011-05-21 A | P3N02UP | 100% | TB26 - 2 - Manuf and Delivy |  | P3N02UN | P3N02UN | 860 | N02U | 17 |  | N02U | 200 | 200 | 400 | P | Chel | L2 | P | N | PN29 | 1704 | M | LND |  |  |
| P3N02ON |  | CA17 SK1705/09 Platforms - Goods arrived at Site | milestone | 0d | 2011-05-29 A | 2011-05-29 A | P3N02OP FF, IMS-P-000090 (other project) FF | 100% | TB26 - 2 - Manuf and Delivy |  | P3N02ON | P3N02ON | 860 | N02O | 17 |  | N02O | 200 | 200 | 400 | P | Chel | L2 | P | N | PN29 | 1704 | SS | LND |  |  |
|  | 1707 | **1707 Connection Piperack - CA17 to CA12** |  |  | 2011-01-11 | 2011-05-16 |  |  |  |  |  |  |  |  |  |  |  |  |  |  |  |  |  |  |  |  |  |  |  |  |  |
|  | N | **N Structural Steel** |  |  | 2011-01-11 | 2011-05-16 |  |  |  |  |  |  |  |  |  |  |  |  |  |  |  |  |  |  |  |  |  |  |  |  |  |
| P3N02VE |  | CA17 SR1707 PR outs. - Vendor Procurement |  | 30d | 2011-01-11 A | 2011-02-09 A | EN27170710 | 100% | TB26 - 2 - Manuf and Delivy |  | P3N02VE | P3N02VE | 860 | N02V | 17 |  | N02V | 200 | 200 | 400 | P | Chel | 0 | P | N | PN25 | 1707 | SS | LND | DEL |  |
| P3N02VL |  | CA17 SR1707 PR outs. - Vendor Fabrication |  | 53d | 2011-03-14 A | 2011-05-06 A | EN281707 SS+20d, P3N02VE SS+20d | 100% | TB26 - 2 - Manuf and Delivy |  | P3N02VL | P3N02VL | 860 | N02V | 17 |  | N02V | 200 | 200 | 400 | P | Chel | 0 | P | N | PN26 | 1707 | SS | LND | DEL |  |
| P3N02VP |  | CA17 SR1707 PR outs. - Transport to Site |  | 46d | 2011-03-31 A | 2011-05-16 A | P3N02VL | 100% | TB26 - 2 - Manuf and Delivy | Piperacks, Main Structures (Delivery) [71 t]; Ladders & Platforms (Delivery) [3 t] | P3N02VP | P3N02VP | 860 | N02V | 17 |  | N02V | 200 | 200 | 400 | P | Chel | 0 | P | N | PN28 | 1707 | SS | LND |  | 0,00 |
| P3N02VN |  | CA17 SR1707 PR outs. - Goods arrived at Site | milestone | 0d | 2011-05-16 A | 2011-05-16 A | P3N02VP FF, P3N100 FF | 100% | TB26 - 2 - Manuf and Delivy |  | P3N02VN | P3N02VN | 860 | N02V | 17 |  | N02V | 200 | 200 | 400 | P | Chel | L2 | P | N | PN29 | 1707 | SS | LND |  |  |

Notes:
- P3N02MN: UDF_Actictity Name (Russia): CA17 Здание экструзии Fl1 SK1701 - Прибытие товара на площадку
- P3N02UN: UDF_Actictity Name (Russia): CA17 SK1704 PR в здании экструзии - Прибытие товара на площадку
- P3N02ON: UDF_Actictity Name (Russia): CA17 SK1704 PR в здании экструзии - Прибытие товара на площадку
- P3N02VN: UDF_Actictity Name (Russia): CA17 SR1707 - Прибытие товара на площадку

| ID | WBS | Activity | Type | Duration | Start | Finish | Predecessors | Complete | Calendar | Resources | UDF_SAVE ACTID | UDF_SAVE ACT ID | Department | Type of Work | Constr. Area | Inquiry/Order No | PMT-Area | PMT-Schedule Org | PMT-Discipline | PMT-Phase | PMT-Doc. Type | PMT-Respons. | Zeigen/n. Zeigen | WBS Phase | WBS Discipline | WBS Type of Work | WBS Objects | IMS | UPT | TB26 Ressource Budget |
| --- | --- | --- | --- | --- | --- | --- | --- | --- | --- | --- | --- | --- | --- | --- | --- | --- | --- | --- | --- | --- | --- | --- | --- | --- | --- | --- | --- | --- | --- | --- |
|  | 1708 | **1708 Connection Piperack - CA17 to CA13** |  |  | 2011-01-11 | 2011-05-11 |  |  |  |  |  |  |  |  |  |  |  |  |  |  |  |  |  |  |  |  |  |  |  |  |
|  | N | **N Structural Steel** |  |  | 2011-01-11 | 2011-05-11 |  |  |  |  |  |  |  |  |  |  |  |  |  |  |  |  |  |  |  |  |  |  |  |  |
| P3N02WE |  | CA17 SR1708 PR outs. - Vendor Procurement |  | 59d | 2011-01-11 A | 2011-03-10 A | EN27170810 | 100% | TB26 - 2 - Manuf and Delivy |  | P3N02WE | P3N02WE | 860 | N02W | 17 | N02W | 200 | 200 | 400 | P | DEL | Chel | 0 | P | N | PN25 | 1708 | SS | LND |  |
| P3N02WL |  | CA17 SR1708 PR outs. - Vendor Fabrication |  | 52d | 2011-03-10 A | 2011-04-30 A | EN281708 SS+30d, P3N02WE SS+20d | 100% | TB26 - 2 - Manuf and Delivy |  | P3N02WL | P3N02WL | 860 | N02W | 17 | N02W | 200 | 200 | 400 | P | DEL | Chel | 0 | P | N | PN26 | 1708 | SS | LND |  |
| P3N02WP |  | CA17 SR1708 PR outs. - Transport to Site |  | 10d | 2011-05-02 A | 2011-05-11 A | P3N02WL | 100% | TB26 - 2 - Manuf and Delivy | Piperacks, Main Structures (Delivery) [71 t]; Ladders & Platforms (Delivery) [3 t] | P3N02WP | P3N02WP | 860 | N02W | 17 | N02W | 200 | 200 | 400 | P |  | Chel | 0 | P | N | PN28 | 1708 | SS | LND | 0,00 |
| P3N02WN |  | CA17 SR1708 PR outs. - Goods arrived at Site | milestone | 0d | 2011-05-11 A | 2011-05-11 A | P3N02WP FF, P3N100 FF | 100% | TB26 - 2 - Manuf and Delivy |  | P3N02WN | P3N02WN | 860 | N02W | 17 | N02W | 200 | 200 | 400 | P |  | Chel | L2 | P | N | PN29 | 1708 | SS | LND |  |
|  | 1710 | **1710 Extrusion Bldg 1st Floor +98,650m (+0,15m) - CA17** |  |  | 2008-04-26 | 2012-01-22 |  |  |  |  |  |  |  |  |  |  |  |  |  |  |  |  |  |  |  |  |  |  |  |  |
|  | N | **N Structural Steel** |  |  | 2010-09-22 | 2011-07-01 |  |  |  |  |  |  |  |  |  |  |  |  |  |  |  |  |  |  |  |  |  |  |  |  |
| P3N02NE |  | CA17 SK1701 Extr Structure - Vendor Procurement 1st Floor (+112m) |  | 35d | 2010-09-22 A | 2010-10-26 A | EN27171110 | 100% | TB26 - 2 - Manuf and Delivy |  | P3N02NE | P3N02NE | 860 | N021 | 17 | N021 | 200 | 200 | 400 | P | DEL | Chel | 0 | P | N | PN25 | 1710 | SS | LND |  |
| P3N02NL |  | CA17 SK1701 Extr Structure - Vendor Fabrication 1st Floor (+112m) |  | 34d | 2010-10-23 A | 2010-11-25 A | P3N02NE SS+20d, EN281711 SS+18d | 100% | TB26 - 2 - Manuf and Delivy |  | P3N02NL | P3N02NL | 860 | N021 | 17 | N021 | 200 | 200 | 400 | P | DEL | Chel | 0 | P | N | PN26 | 1710 | SS | LND |  |
| P3N02NP |  | CA17 SK1701 Extr Structure - Transport to Site 1st Floor (+112m) |  | 5d | 2010-11-26 A | 2010-11-30 A | P3N02NL | 100% | TB26 - 2 - Manuf and Delivy | Piperacks, Main Structures (Delivery) [40 t]; Ladders & Platforms (Delivery) [18 t] | P3N02NP | P3N02NP | 860 | N021 | 17 | N021 | 200 | 200 | 400 | P |  | Chel | 0 | P | N | PN28 | 1710 | SS | LND | 0,00 |
| P3N02NN |  | CA17 SK1701 Extr Structure - 1st LOT arrived at Site (+112m) | milestone | 0d | 2010-11-30 A | 2010-11-30 A | P3N02NP | 100% | TB26 - 2 - Manuf and Delivy |  | P3N02NN | P3N02NN | 860 | N021 | 17 | N021 | 200 | 200 | 400 | P |  | Chel | L2 | P | N | PN29 | 1710 | M | LND |  |
| P3N022E |  | CA17 SK1701 Extr Structure - Vendor Procurement 2nd Floor (+118m) |  | 30d | 2011-01-06 A | 2011-02-04 A | EN27171120 | 100% | TB26 - 2 - Manuf and Delivy |  | P3N022E | P3N022E | 860 | N022 | 17 | N022 | 200 | 200 | 400 | P | DEL | Chel | 0 | P | N | PN25 | 1710 | SS | LND |  |
| P3N023E |  | CA17 SK1701 Extr Structure - Vendor Procurement 3rd Floor (+124m) |  | 52d | 2011-01-25 A | 2011-03-17 A | EN27171145 FS+5d | 100% | TB26 - 2 - Manuf and Delivy |  | P3N023E | P3N023E | 860 | N023 | 17 | N023 | 200 | 200 | 400 | P | DEL | Chel | 0 | P | N | PN25 | 1710 | SS | LND |  |
| P3N024E |  | CA17 SK1701 Extr Structure - Vendor Procurement 4th Floor (+130m) |  | 60d | 2011-01-25 A | 2011-03-25 A | EN27171130 | 100% | TB26 - 2 - Manuf and Delivy |  | P3N024E | P3N024E | 860 | N024 | 17 | N024 | 200 | 200 | 400 | P | DEL | Chel | 0 | P | N | PN25 | 1710 | SS | LND |  |
| PN661710 |  | CA17 ExtrBldgFl1 - Fabrication Gratings |  | 50d | 2011-01-27 A | 2011-03-17 A | EN681711, EN641711 | 100% | TB26 - 2 - Manuf and Delivy |  | PN661710 | PN661710 | 860 | N021 | 17 | N021 | 200 | 200 |  | C |  |  |  | P | N | PN66 | 1710 | SS | LND |  |
| P3N022L |  | CA17 SK1701 Extr Structure - Vendor Fabrication 2nd Floor (+118m) |  | 51d | 2011-02-03 A | 2011-03-25 A | EN28171105 SS+20d, P3N022E SS+10d | 100% | TB26 - 2 - Manuf and Delivy |  | P3N022L | P3N022L | 860 | N022 | 17 | N022 | 200 | 200 | 400 | P | DEL | Chel | 0 | P | N | PN26 | 1710 | SS | LND |  |
| A1010330 |  | CA17 SK1701 Extr Structure - Vendor Procurement 5th Floor (+136m) |  | 65d | 2011-02-09 A | 2011-04-14 A | EN27171155 FS+10d | 100% | TB26 - 2 - Manuf and Delivy |  | A1010330 | A1010330 | 860 | N025 | 17 | N025 | 200 | 200 | 400 | P | DEL | Chel | 0 | P | N | PN25 | 1710 | SS | LND |  |
| P3N02§E |  | CA17 SK1706 Cladding Support Str - Vendor Procurement |  | 45d | 2011-02-22 A | 2011-04-07 A | EN27170610 FS-10d | 100% | TB26 - 2 - Manuf and Delivy |  | P3N02§E | P3N02§E | 860 | N02§ | 17 | N02§ | 200 | 200 | 400 | P | DEL | Chel | 0 | P | N | PN25 | 1710 | SS | LND |  |
| P3N02§L |  | CA17 SK1706 Cladding Support Str - Vendor Fabrication |  | 70d | 2011-03-10 A | 2011-05-19 A | P3N02§E SS+15d, EN271706 SS+15d | 100% | TB26 - 2 - Manuf and Delivy |  | P3N02§L | P3N02§L | 860 | N02§ | 17 | N02§ | 200 | 200 | 400 | P | DEL | Chel | 0 | P | N | PN26 | 1710 | SS | LND |  |
| PN681710 |  | CA17 ExtrBldgFl1 - Transport Gratings to Site |  | 10d | 2011-03-18 A | 2011-03-27 A | PN661710 | 100% | TB26 - 2 - Manuf and Delivy |  | PN681710 | PN681710 | 860 | N021 | 17 | N021 | 200 | 200 |  | C |  |  |  | P | N | PN68 | 1710 | SS | LND |  |
| P3N022P |  | CA17 SK1701 Extr Structure - Transport to Site 2nd Floor (+118m) |  | 5d | 2011-03-26 A | 2011-03-30 A | P3N022L | 100% | TB26 - 2 - Manuf and Delivy | Piperacks, Main Structures (Delivery) [560 t] | P3N022P | P3N022P | 860 | N022 | 17 | N022 | 200 | 200 | 400 | P |  | Chel | 0 | P | N | PN28 | 1710 | SS | LND | 0,00 |
| PN691710 |  | CA17 ExtrBldgFl1 - Gratings arrived at Site | milestone | 0d | 2011-03-27 A | 2011-03-27 A | PN681710 FF | 100% | TB26 - 2 - Manuf and Delivy |  | PN691710 | PN691710 | 860 | N021 | 17 | N021 | 200 | 200 |  | C |  |  |  | P | N | PN69 | 1710 | S | LND |  |
| P3N023L |  | CA17 SK1701 Extr Structure - Vendor Fabrication 3rd Floor (+124m) |  | 53d | 2011-03-29 A | 2011-05-21 A | P3N023E SS+20d, EN28171130 SS+30d | 100% | TB26 - 2 - Manuf and Delivy |  | P3N023L | P3N023L | 860 | N023 | 17 | N023 | 200 | 200 | 400 | P | DEL | Chel | 0 | P | N | PN26 | 1710 | SS | LND |  |
| P3N024L |  | CA17 SK1701 Extr Structure - Vendor Fabrication 4th Floor (+130m) |  | 53d | 2011-03-29 A | 2011-05-21 A | P3N024E SS+20d, EN28171140 SS+35d | 100% | TB26 - 2 - Manuf and Delivy |  | P3N024L | P3N024L | 860 | N024 | 17 | N024 | 200 | 200 | 400 | P | DEL | Chel | 0 | P | N | PN26 | 1710 | SS | LND |  |
| P3N022N |  | CA17 SK1701 Extr Structure - 2nd LOT arrived at Site (<118m) 1st Part | milestone | 0d | 2011-03-30 A | 2011-03-30 A | P3N022P | 100% | TB26 - 2 - Manuf and Delivy |  | P3N022N | P3N022N | 860 | N022 | 17 | N022 | 200 | 200 | 400 | P |  | Chel | C9 | P | N | PN29 | 1710 | M | LND |  |
| P3N02§P |  | CA17 SK1706 Cladding Support Str - Transport to Site |  | 50d | 2011-04-09 A | 2011-05-29 A | P3N02§L FF+10d | 100% | TB26 - 2 - Manuf and Delivy | Piperacks, Main Structures (Delivery) [230 t] | P3N02§P | P3N02§P | 860 | N02§ | 17 | N02§ | 200 | 200 | 400 | P |  | Chel | 0 | P | N | PN28 | 1710 | SS | LND | 0,00 |
| P3N02§N |  | CA17 SK1706 Cladding Support Str - 1st Goods arrived at Site | milestone | 0d | 2011-04-23 A | 2011-04-23 A | P3N02§P SF+15d | 100% | TB26 - 2 - Manuf and Delivy |  | P3N02§N | P3N02§N | 860 | N02§ | 17 | N02§ | 200 | 200 | 400 | P |  | Chel | L2 | P | N | PN29 | 1710 | M | LND |  |
| A1010350 |  | CA17 SK1701 Extr Structure - Vendor Fabrication 5th Floor (+136m) |  | 55d | 2011-04-27 A | 2011-06-21 A | A1010330 SS+45d, EN28171150 SS+55d | 100% | TB26 - 2 - Manuf and Delivy |  | A1010350 | A1010350 | 860 | N025 | 17 | N025 | 200 | 200 | 400 | P | DEL | Chel | 0 | P | N | PN26 | 1710 | SS | LND |  |
| P3N023P |  | CA17 SK1701 Extr Structure - Transport to Site 3rd Floor (+124m) |  | 5d | 2011-05-22 A | 2011-05-26 A | P3N023L | 100% | TB26 - 2 - Manuf and Delivy | Piperacks, Main Structures (Delivery) [500 t] | P3N023P | P3N023P | 860 | N023 | 17 | N023 | 200 | 200 | 400 | P |  | Chel | 0 | P | N | PN28 | 1710 | SS | LND | 0,00 |
| P3N024P |  | CA17 SK1701 Extr Structure - Transport to Site 4th Floor (+130m) |  | 10d | 2011-05-22 A | 2011-05-31 A | P3N024L | 100% | TB26 - 2 - Manuf and Delivy | Piperacks, Main Structures (Delivery) [460 t] | P3N024P | P3N024P | 860 | N024 | 17 | N024 | 200 | 200 | 400 | P |  | Chel | 0 | P | N | PN28 | 1710 | SS | LND | 0,00 |
| P3N023N |  | CA17 SK1701 Extr Structure - 3rd LOT arrived at Site (<124m) | milestone | 0d | 2011-05-26 A | 2011-05-26 A | P3N023P | 100% | TB26 - 2 - Manuf and Delivy |  | P3N023N | P3N023N | 860 | N023 | 17 | N023 | 200 | 200 | 400 | P |  | Chel | C9 | P | N | PN29 | 1710 | M | LND |  |
| P3N024N |  | CA17 SK1701 Extr Structure - 4th LOT arrived at Site (<130m) | milestone | 0d | 2011-05-31 A | 2011-05-31 A | P3N024P | 100% | TB26 - 2 - Manuf and Delivy |  | P3N024N | P3N024N | 860 | N024 | 17 | N024 | 200 | 200 | 400 | P |  | Chel | C9 | P | N | PN29 | 1710 | M | LND |  |
| A1010360 |  | CA17 SK1701 Extr Structure - Transport to Site 5th Floor (+136m) |  | 10d | 2011-06-22 A | 2011-07-01 A | A1010350 | 100% | TB26 - 2 - Manuf and Delivy | Piperacks, Main Structures (Delivery) [280 t] | A1010360 | A1010360 | 860 | N025 | 17 | N025 | 200 | 200 | 400 | P |  | Chel | 0 | P | N | PN28 | 1710 | SS | LND | 0,00 |
| P3N025N |  | CA17 SK1701 Extr Structure - 5th LOT arrived at Site (<136m) | milestone | 0d | 2011-07-01 A | 2011-07-01 A | A1010360 | 100% | TB26 - 2 - Manuf and Delivy |  | P3N025N | P3N025N | 860 | N025 | 17 | N025 | 200 | 200 | 400 | P |  | Chel | C9 | P | N | PN29 | 1710 | M | LND |  |

Notes:
- P3N02WN: UDF_Actictity Name (Russia): CA17 SR1708 - Прибытие товара на площадку
- P3N02NN: UDF_Actictity Name (Russia): CA17 Здание экструзии Fl2 SK1702 - Прибытие товара на площадку
- P3N02§N: UDF_Actictity Name (Russia): CA17 Здание экструзии Fl2 SK1702 - Прибытие товара на площадку

| ID | WBS | Activity | Type | Duration | Start | Finish | Predecessors | Complete | Total float | Free float | Calendar | Cost | Actual cost | UDF_SAVE ACTID | UDF_SAVE ACT ID | Department | Type of Work | Constr. Area | Inquiry/Order No | PMT-Area | PMT-Schedule Org | PMT-Discipline | PMT-Phase | PMT-Respons. | Zeigen/n. Zeigen | WBS Phase | WBS Discipline | WBS Type of Work | WBS Objects | IMS | UPT | Pro Unit/DocCode | PMT-Doc. Type |
| --- | --- | --- | --- | --- | --- | --- | --- | --- | --- | --- | --- | --- | --- | --- | --- | --- | --- | --- | --- | --- | --- | --- | --- | --- | --- | --- | --- | --- | --- | --- | --- | --- | --- |
|  | H | **H HVAC** |  |  | 2011-10-15 | 2011-10-15 |  |  |  |  |  |  |  |  |  |  |  |  |  |  |  |  |  |  |  |  |  |  |  |  |  |  |  |
| P3H01SI |  | H01 HVAC Eqt. - 1stGoods arr. at Site CA17 (1st) | milestone | 0d | 2011-10-15 | 2011-10-15 | P3H01P SF+200d |  | -43d | 50d | TB26 - 2 - Manuf and Delivy |  |  | P3H01SI | P3H01SI | 860 | H01 | 17 | H01 | 000 | 200 | 400 | P | SC | L2 | P | H | PH19 | 1710 | hva_as | LND |  |  |
|  | U | **U Package Units** |  |  | 2010-10-22 | 2011-01-02 |  |  |  |  |  |  |  |  |  |  |  |  |  |  |  |  |  |  |  |  |  |  |  |  |  |  |  |
| P3U10S1B |  | PU10 Convey. Syst. - Goods arr. at site 1st LOT | milestone | 0d | 2010-10-22 A | 2010-10-22 A | P3U10N1 | 100% |  |  | TB26 - 2 - Manuf and Delivy |  |  | P3U10S1B | P3U10S1B | 860 | PU10 | 17 | 2DC8990 | 200 | 200 | 400 | P | OWN | C2 | P | U | PU19 | 1710 | S | LND | DC |  |
| P3U10S2B |  | PU10 Convey. Syst. - Goods arr. at site 2nd LOT | milestone | 0d | 2011-01-02 A | 2011-01-02 A | P3U10N4 FF | 100% |  |  | TB26 - 2 - Manuf and Delivy |  |  | P3U10S2B | P3U10S2B | 860 | PU10 | 17 | 2DC8990 | 200 | 200 | 400 | P | OWN |  | P | U | PU19 | 1710 | S | LND | DC |  |
|  | B | **B Mechanical - Stationary Equipment** |  |  | 2010-11-30 | 2011-10-08 |  |  |  |  |  |  |  |  |  |  |  |  |  |  |  |  |  |  |  |  |  |  |  |  |  |  |  |
| P3A13S4 |  | A13 Scales - Goods arr. at Site CA17 (MI-21402) | milestone | 0d | 2010-11-30 A | 2010-11-30 A | P3A13N FF | 100% |  |  | TB26 - 2 - Manuf and Delivy |  |  | P3A13S4 | P3A13S4 | 860 | A13 | 17 | 2DC9060 | 200 | 200 | 400 | P | OWN |  | P | B | PB99 | 1710 | S | LND |  |  |
| P3A02S6 |  | A02A Large Drums - Goods arrived at Site CA17 (1st LOT) | milestone | 0d | 2011-03-07 A | 2011-03-07 A | P3A02AX FF+25d | 100% |  |  | TB26 - 2 - Manuf and Delivy |  |  | P3A02S6 | P3A02S6 | 860 | A02A | 17 | 2DC9450 | 200 | 200 | 400 | P | OWN |  | P | B | PB19 | 1710 | S | LND |  |  |
| P3A06AS1 |  | A06A Electrical Heater - Goods arr. at Site CA17 | milestone | 0d | 2011-06-10 A | 2011-06-10 A | HPBA06A FF, P3A06AG, P3A06AN FF | 100% |  |  | TB26 - 2 - Manuf and Delivy |  |  | P3A06AS1 | P3A06AS1 | 860 | A06A | 17 | 2DC9080 | 200 | 200 | 400 | P | OWN |  | P | B | PB29 | 1710 | S | LND |  |  |
| P3A12S1 |  | A12 Overhead Cranes - Goods arrived at Site CA17 | milestone | 0d | 2011-09-25 | 2011-09-25 | P3A12N FF, HPBA12 FF |  | 537.5d | 114d | TB26 - 2 - Manuf and Delivy |  |  | P3A12S1 | P3A12S1 | 860 | A12 | 17 | 2KB4740 | 200 | 200 | 400 | P | OWN | 0 | P | B | PB99 | 1710 | S | LND |  |  |
| P3A06S3 |  | A06 Start-Up Heater/Condenser - Goods arr. at Site CA17 | milestone | 0d | 2011-10-08 | 2011-10-08 | P3A06N FF |  | 38d | 129d | TB26 - 2 - Manuf and Delivy |  |  | P3A06S3 | P3A06S3 | 860 | A06 | 17 | 2DD8530 | 200 | 200 | 400 | P | OWN |  | P | B | PB29 | 1710 | S | LND |  |  |
|  | M | **M Mechanical - Rotating Equipment** |  |  | 2008-04-26 | 2012-01-22 |  |  |  |  |  |  |  |  |  |  |  |  |  |  |  |  |  |  |  |  |  |  |  |  |  |  |  |
| P3M01L |  | M01 Extruder Pck. - Lead Time/Fabrication |  | 1003d | 2008-04-26 A | 2011-02-04 A | P3M01D | 100% |  |  | TB26 - 2 - Manuf and Delivy |  |  | P3M01L | P3M01L | 860 | M01 | 17 | 2DC8480 | 200 | 200 | 400 | P | LND | C3 | P | M | PM36 | 1710 | E | LND | DC | DEL |
| P3M01L1 |  | M01 Extruder Pck. - Slow Down/Minimize Engin / Design Works |  | 590d | 2008-04-26 A | 2009-12-11 A | P3M01L SS | 100% |  |  | TB26 - 2 - Manuf and Delivy |  |  | P3M01L1 | P3M01L1 | 860 | M01 | 17 | 2DC8480 | 200 | 200 | 400 | P | LND | C3 | P | M | PM36 | 1710 | E | LND | DC | DEL |
| P3M15S2 |  | M15 Conds./BoosterP - Goods arrived at Site CA17 | milestone | 0d | 2011-01-27 A | 2011-01-27 A | P3M15N FF, P3M15G | 100% |  |  | TB26 - 2 - Manuf and Delivy |  |  | P3M15S2 | P3M15S2 | 860 | M15 | 17 | 2PA6720 | 200 | 200 | 400 | P | OWN |  | P | M | PM98 | 1710 | S | LND |  |  |
| P3M01M |  | M01 Extruder Pck. - Goods delivered FOB Japan | milestone | 0d | 2011-02-14 A | 2011-02-14 A | P3M01L FF+10d, P3M01X1, E3M0170 | 100% |  |  | TB26 - 2 - Manuf and Delivy | 2,551,530 | 2,551,530 | P3M01M | P3M01M | 860 | M01 | 17 | 2DC8480 | 200 | 200 | 400 | P | LND | C3 | P | M | PM38 | 1710 | E | LND | DC |  |
| P3M01N1 |  | M01 Extruder Pck. - Shipment Japan-Russia East |  | 10d | 2011-02-15 A | 2011-02-24 A | P3M01M | 100% |  |  | TB26 - 2 - Manuf and Delivy |  |  | P3M01N1 | P3M01N1 | 860 | M01 | 17 | 2DC8480 | 200 | 200 | 400 | P | LND | C3 | P | M | PM38 | 1710 | E | LND | DC |  |
| P3M01N3 |  | M01 Extruder Pck. - Train East Port-Tobolsk |  | 44d | 2011-02-25 A | 2011-04-09 A | P3M01N1 | 100% |  |  | TB26 - 2 - Manuf and Delivy |  |  | P3M01N3 | P3M01N3 | 860 | M01 | 17 | 2DC8480 | 200 | 200 | 400 | P | LND | C3 | P | M | PM38 | 1710 | E | LND | DC |  |
| P3m01SD |  | M01 Extruder Pck. - Motor Pck. Goods arrived at site | milestone | 0d | 2011-04-08 A | 2011-04-08 A | P3M01N2 | 100% |  |  | TB26 - 2 - Manuf and Delivy |  |  | P3m01SD | P3m01SD | 860 | M01 | 17 | 2DC8480 | 200 | 200 | 400 | P | OWN | C2 | P | M | PM39 | 1710 | S | LND | DC |  |
| P3M01N5 |  | M01 Extruder Pck. - Custom clearance Period |  | 3d | 2011-04-10 A | 2011-04-12 A | P3M01N3 | 100% |  |  | TB26 - 2 - Manuf and Delivy |  |  | P3M01N5 | P3M01N5 | 860 | M01 | 17 | 2DC8480 | 200 | 200 | 400 | P | LND | C3 | P | M | PM38 | 1710 | E | LND | DC |  |
| P3M01SA |  | M01 Extruder Pck. - Goods arrived at site | milestone | 0d | 2011-04-12 A | 2011-04-12 A | P3M01N FF, P3M01N5 FF, P3M01G, HPMM01 FF | 100% |  |  | TB26 - 2 - Manuf and Delivy | 1,701,020 | 1,701,020 | P3M01SA | P3M01SA | 860 | M01 | 17 | 2DC8480 | 200 | 200 | 400 | P | OWN |  | P | M | PM39 | 1710 | S | LND | DC |  |
| P3M01AS |  | M01A PCW Cooler - Goods arrived at Site CA17 | milestone | 0d | 2011-05-06 A | 2011-05-06 A | P3M01AN FF, P3M01AG | 100% |  |  | TB26 - 2 - Manuf and Delivy |  |  | P3M01AS | P3M01AS | 860 | M01A | 17 | 2KB9850 | 200 | 200 | 400 | P | OWN |  | P | M | PM19 | 1710 | S | LND |  |  |
| P3M16S |  | M16 Instr. Air Comp - Goods arrived at Site CA17 | milestone | 0d | 2011-07-20 A | 2011-07-20 A | P3M16G, E3M1670, HPMM16 FF, P3M16N FF | 100% |  |  | TB26 - 2 - Manuf and Delivy | 33,058 | 33,058 | P3M16S | P3M16S | 860 | M16 | 17 | 2KB4660 | 200 | 200 | 400 | P | OWN |  | P | M | PM19 | 1710 | S | LND |  |  |
| P3M14S2 |  | M14 Submers. Pumps - Goods arrived at Site CA17 | milestone | 0d | 2011-10-18 | 2011-10-18 | P3M14N FF, P3M14G |  | -9d | 0d | TB26 - 2 - Manuf and Delivy |  |  | P3M14S2 | P3M14S2 | 860 | M14 | 17 | 2PA6900 | 200 | 200 | 400 | P | OWN |  | P | M | PM98 | 1710 | S | LND |  |  |
| P3M17S |  | M17 Chiller Unit - Goods arrived at Site CA17 | milestone | 0d | 2012-01-22 | 2012-01-22 | P3M17G, E3M1670, P3M17N FF |  | 214d | 238.5d | TB26 - 2 - Manuf and Delivy |  |  | P3M17S | P3M17S | 860 | M17 | 17 | 2KB9890 | 200 | 200 | 400 | P | OWN |  | P | M | PM19 | 1710 | S | LND |  |  |

Notes:
- P3H01SI: UDF_Actictity Name (Russia): H01 Оборудование ОВКВ - Прибытие 1-й партии товара на площадку, CA17 (1)
- P3M01M: Expenses: 900A 2551530
- P3M01N1: P3 Activity Log Info: Russia East Port / (Wladiwostok/Nakhodka)
- P3M01N3: P3 Activity Log Info: 30days container / transport, 50days heavy equip.
- P3M01SA: Expenses: 900A 1701020
- P3M16S: Expenses: 900A 33058

| ID | WBS | Activity | Type | Duration | Start | Finish | Predecessors | Complete | Total float | Free float | Calendar | Cost | Actual cost | UDF_SAVE ACTID | UDF_SAVE ACT ID | Department | Type of Work | Constr. Area | Inquiry/Order No | PMT-Area | PMT-Schedule Org | PMT-Discipline | PMT-Phase | PMT-Respons. | Zeigen/n. Zeigen | WBS Phase | WBS Discipline | WBS Type of Work | WBS Objects | IMS | UPT | Pro Unit/DocCode |
| --- | --- | --- | --- | --- | --- | --- | --- | --- | --- | --- | --- | --- | --- | --- | --- | --- | --- | --- | --- | --- | --- | --- | --- | --- | --- | --- | --- | --- | --- | --- | --- | --- |
|  | E | **E Electrical** |  |  | 2010-12-04 | 2011-05-25 |  |  |  |  |  |  |  |  |  |  |  |  |  |  |  |  |  |  |  |  |  |  |  |  |  |  |
| P3E02S3 |  | E02 PowerTransformer - Goods arr. at SiteCA17 | milestone | 0d | 2010-12-04 A | 2010-12-04 A | P3E02N, P3E02G | 100% |  |  | TB26 - 2 - Manuf and Delivy |  |  | P3E02S3 | P3E02S3 | 860 | E02 | 17 | 2EB5620 | 200 | 200 | 400 | P | OWN | 0 | P | E | EE20 | 1710 | ELE | LND |  |
| P3E07S2 |  | E07 UPS/DC-System - Goods arriv. at Site CA17 | milestone | 0d | 2011-05-25 A | 2011-05-25 A | P3E07G, P3E07N FF | 100% |  |  | TB26 - 2 - Manuf and Delivy |  |  | P3E07S2 | P3E07S2 | 860 | E07 | 17 | 2EB5610 | 200 | 200 | 400 | P | OWN | 0 | P | E | EE24 | 1710 | IT | LND |  |
|  | J | **J Instrumentation** |  |  | 2011-07-15 | 2011-07-15 |  |  |  |  |  |  |  |  |  |  |  |  |  |  |  |  |  |  |  |  |  |  |  |  |  |  |
| P3J06S2 |  | J06 DCS / SIS - Goods arr.at Site CA17 | milestone | 0d | 2011-07-15 A | 2011-07-15 A | P3J06N FF | 100% |  |  | TB26 - 2 - Manuf and Delivy |  |  | P3J06S2 | P3J06S2 | 860 | J06 | 17 | 2JD9220 | 200 | 200 | 400 | P | LND | 0 | P | J | PJ29 | 1710 | INS | LND |  |
|  | 1718 | **1718 Extrusion Bldg 2nd Floor +111,250m (+12,75m) - CA17** |  |  | 2010-10-22 | 2011-12-09 |  |  |  |  |  |  |  |  |  |  |  |  |  |  |  |  |  |  |  |  |  |  |  |  |  |  |
|  | N | **N Structural Steel** |  |  | 2011-01-27 | 2011-04-26 |  |  |  |  |  |  |  |  |  |  |  |  |  |  |  |  |  |  |  |  |  |  |  |  |  |  |
| PN661718 |  | CA17 ExtrBldgFl2 - Fabrication Gratings |  | 80d | 2011-01-27 A | 2011-04-16 A | EN681711 | 100% |  |  | TB26 - 2 - Manuf and Delivy |  |  | PN661718 | PN661718 | 860 | XNK | 17 |  | 200 | 200 |  | C |  |  | P | N | PN66 | 1718 | SS | LND |  |
| PN681718 |  | CA17 ExtrBldgFl2 - Transport Gratings to Site |  | 10d | 2011-04-17 A | 2011-04-26 A | PN661718 | 100% |  |  | TB26 - 2 - Manuf and Delivy |  |  | PN681718 | PN681718 | 860 | XNK | 17 |  | 200 | 200 |  | C |  |  | P | N | PN68 | 1718 | SS | LND |  |
| PN691718 |  | CA17 ExtrBldgFl2 - Gratings arrived at Site | milestone | 0d | 2011-04-26 A | 2011-04-26 A | PN681718 FF | 100% |  |  | TB26 - 2 - Manuf and Delivy |  |  | PN691718 | PN691718 | 860 | XNK | 17 |  | 200 | 200 |  | C |  |  | P | N | PN69 | 1718 | S | LND |  |
|  | H | **H HVAC** |  |  | 2011-09-25 | 2011-09-25 |  |  |  |  |  |  |  |  |  |  |  |  |  |  |  |  |  |  |  |  |  |  |  |  |  |  |
| P3H01SJ |  | H01 HVAC Eqt. - 1stGoods arr. at Site CA17 (2nd) | milestone | 0d | 2011-09-25 | 2011-09-25 | P3H01P SF+180d |  | 141d | 35d | TB26 - 2 - Manuf and Delivy |  |  | P3H01SJ | P3H01SJ | 860 | H01 | 17 | H01 | 000 | 200 | 400 | P | SC | L2 | P | H | PH19 | 1718 | hva_as | LND |  |
|  | U | **U Package Units** |  |  | 2010-10-22 | 2011-07-27 |  |  |  |  |  |  |  |  |  |  |  |  |  |  |  |  |  |  |  |  |  |  |  |  |  |  |
| P3U10S1D |  | PU10 Convey. Syst. - Goods arr. at site 1st LOT | milestone | 0d | 2010-10-22 A | 2010-10-22 A | P3U10N1 | 100% |  |  | TB26 - 2 - Manuf and Delivy |  |  | P3U10S1D | P3U10S1D | 860 | PU10 | 17 | 2DC8990 | 200 | 200 | 400 | P | OWN | C2 | P | U | PU19 | 1718 | S | LND | DC |
| P3U02S4 |  | PU02 Add. Feed Syst.- Goods arrived at site CA17 | milestone | 0d | 2010-11-25 A | 2010-11-25 A | P3U02N FF | 100% |  |  | TB26 - 2 - Manuf and Delivy |  |  | P3U02S4 | P3U02S4 | 860 | PU02 | 17 | 2DC9820 | 200 | 200 | 400 | P | OWN | C2 | P | U | PU29 | 1718 | S | LND | DC |
| P3U10S2A |  | PU10 Convey. Syst. - Goods arr. at site 2nd LOT | milestone | 0d | 2010-12-23 A | 2010-12-23 A | P3U10N4 FF | 100% |  |  | TB26 - 2 - Manuf and Delivy | 831,615 | 831,615 | P3U10S2A | P3U10S2A | 860 | PU10 | 17 | 2DC8990 | 200 | 200 | 400 | P | OWN | C2 | P | U | PU19 | 1718 | S | LND | DC |
| P3U22S2 |  | PU22 Vacuum System - Goods arrived at Site CA17 | milestone | 0d | 2011-07-27 A | 2011-07-27 A | P3U22N FF, P3U22G | 100% |  |  | TB26 - 2 - Manuf and Delivy |  |  | P3U22S2 | P3U22S2 | 860 | PU22 | 17 | 2DC9170 | 200 | 200 | 400 | P | OWN | 0 | P | U | PU99 | 1718 | S | LND |  |
|  | M | **M Mechanical - Rotating Equipment** |  |  | 2011-06-21 | 2011-06-21 |  |  |  |  |  |  |  |  |  |  |  |  |  |  |  |  |  |  |  |  |  |  |  |  |  |  |
| P3M12S1 |  | M12 Rotary Feeder - Goods arrived at Site CA17 | milestone | 0d | 2011-06-21 A | 2011-06-21 A | P3M12G, P3M12N FF, E3M1270 | 100% |  |  | TB26 - 2 - Manuf and Delivy | 77,901 | 77,901 | P3M12S1 | P3M12S1 | 860 | M12 | 17 | 2DC8940 | 200 | 200 | 400 | P | OWN | 0 | P | M | PM98 | 1718 | S | LND |  |
|  | R | **R Piping** |  |  | 2011-12-09 | 2011-12-09 |  |  |  |  |  |  |  |  |  |  |  |  |  |  |  |  |  |  |  |  |  |  |  |  |  |  |
| P3R09AS |  | R09A Expansion Joints -Material arr at Site CA17 | milestone | 0d | 2011-12-09 | 2011-12-09 | HPRR09A FF, P3R09AN FF |  | 7d | 60d | TB26 - 2 - Manuf and Delivy | 18,383 |  | P3R09AS | P3R09AS | 860 | R09A | 17 | R09A | 200 | 200 | 400 | P | OWN | 0 | P | R | PR29 | 1718 | AG | LND |  |
|  | 1720 | **1720 Extrusion Bldg 3rd Floor +117,550m (+19,05m) - CA17** |  |  | 2010-10-22 | 2011-10-25 |  |  |  |  |  |  |  |  |  |  |  |  |  |  |  |  |  |  |  |  |  |  |  |  |  |  |
|  | N | **N Structural Steel** |  |  | 2011-01-27 | 2011-04-26 |  |  |  |  |  |  |  |  |  |  |  |  |  |  |  |  |  |  |  |  |  |  |  |  |  |  |
| PN661720 |  | CA17 ExtrBldgFl3 - Fabrication Gratings |  | 80d | 2011-01-27 A | 2011-04-16 A | EN681711 | 100% |  |  | TB26 - 2 - Manuf and Delivy |  |  | PN661720 | PN661720 | 860 | XNK | 17 |  | 200 | 200 |  | C |  |  | P | N | PN66 | 1720 | SS | LND |  |
| PN681720 |  | CA17 ExtrBldgFl3 - Transport Gratings to Site |  | 10d | 2011-04-17 A | 2011-04-26 A | PN661720 | 100% |  |  | TB26 - 2 - Manuf and Delivy |  |  | PN681720 | PN681720 | 860 | XNK | 17 |  | 200 | 200 |  | C |  |  | P | N | PN68 | 1720 | SS | LND |  |
| PN691720 |  | CA17 ExtrBldgFl3 - Gratings arrived at Site | milestone | 0d | 2011-04-26 A | 2011-04-26 A | PN681720 FF | 100% |  |  | TB26 - 2 - Manuf and Delivy |  |  | PN691720 | PN691720 | 860 | XNK | 17 |  | 200 | 200 |  | C |  |  | P | N | PN69 | 1720 | S | LND |  |

Notes:
- P3H01SJ: UDF_Actictity Name (Russia): H01 Оборудование ОВКВ - Прибытие 1-й партии товара на площадку, CA17 (2)
- P3U10S2A: Expenses: 900A 831615
- P3M12S1: Expenses: 900A 77901
- P3R09AS: Expenses: 900A 18383

| ID | WBS | Activity | Type | Duration | Start | Finish | Predecessors | Complete | Total float | Free float | Calendar | Cost | Actual cost | UDF_SAVE ACTID | UDF_SAVE ACT ID | Department | Type of Work | Constr. Area | Inquiry/Order No | PMT-Area | PMT-Schedule Org | PMT-Discipline | PMT-Phase | PMT-Respons. | Zeigen/n. Zeigen | WBS Phase | WBS Discipline | WBS Type of Work | WBS Objects | IMS | UPT | Pro Unit/DocCode |
| --- | --- | --- | --- | --- | --- | --- | --- | --- | --- | --- | --- | --- | --- | --- | --- | --- | --- | --- | --- | --- | --- | --- | --- | --- | --- | --- | --- | --- | --- | --- | --- | --- |
|  | H | **H HVAC** |  |  | 2011-10-25 | 2011-10-25 |  |  |  |  |  |  |  |  |  |  |  |  |  |  |  |  |  |  |  |  |  |  |  |  |  |  |
| P3H01SK |  | H01 HVAC Eqt. - 1stGoods arr. at Site CA17 (3rd) | milestone | 0d | 2011-10-25 | 2011-10-25 | P3H01P SF+210d |  | 101d | 30d | TB26 - 2 - Manuf and Delivy |  |  | P3H01SK | P3H01SK | 860 | H01 | 17 | H01 | 000 | 200 | 400 | P | SC | L2 | P | H | PH19 | 1720 | hva_as | LND |  |
|  | U | **U Package Units** |  |  | 2010-10-22 | 2011-01-02 |  |  |  |  |  |  |  |  |  |  |  |  |  |  |  |  |  |  |  |  |  |  |  |  |  |  |
| P3U10S1C |  | PU10 Convey. Syst. - Goods arr. at site 1st LOT | milestone | 0d | 2010-10-22 A | 2010-10-22 A | P3U10N1 | 100% |  |  | TB26 - 2 - Manuf and Delivy |  |  | P3U10S1C | P3U10S1C | 860 | PU10 | 17 | 2DC8990 | 200 | 200 | 400 | P | OWN | C2 | P | U | PU19 | 1720 | S | LND | DC |
| P3U02S5 |  | PU02 Add. Feed Syst.- Goods arrived at site CA17 | milestone | 0d | 2010-11-25 A | 2010-11-25 A | P3U02N FF | 100% |  |  | TB26 - 2 - Manuf and Delivy |  |  | P3U02S5 | P3U02S5 | 860 | PU02 | 17 | 2DC9820 | 200 | 200 | 400 | P | OWN | C2 | P | U | PU29 | 1720 | S | LND | DC |
| P3U10S2C |  | PU10 Convey. Syst. - Goods arr. at site 2nd LOT | milestone | 0d | 2011-01-02 A | 2011-01-02 A | P3U10N4 FF | 100% |  |  | TB26 - 2 - Manuf and Delivy |  |  | P3U10S2C | P3U10S2C | 860 | PU10 | 17 | 2DC8990 | 200 | 200 | 400 | P | OWN | C2 | P | U | PU19 | 1720 | S | LND | DC |
|  | M | **M Mechanical - Rotating Equipment** |  |  | 2011-04-12 | 2011-04-12 |  |  |  |  |  |  |  |  |  |  |  |  |  |  |  |  |  |  |  |  |  |  |  |  |  |  |
| P3M01SC |  | M01 Extruder Pck. - Goods arrived at site | milestone | 0d | 2011-04-12 A | 2011-04-12 A | P3M01N5, P3M01N | 100% |  |  | TB26 - 2 - Manuf and Delivy |  |  | P3M01SC | P3M01SC | 860 | M01 | 17 | 2DC8480 | 200 | 200 | 400 | P | OWN | C2 | P | M | PM39 | 1720 | S | LND | DC |
|  | 1730 | **1730 Extrusion Bldg 4th Floor +123,850m (+25,35m) - CA17** |  |  | 2010-11-25 | 2011-11-24 |  |  |  |  |  |  |  |  |  |  |  |  |  |  |  |  |  |  |  |  |  |  |  |  |  |  |
|  | N | **N Structural Steel** |  |  | 2011-01-27 | 2011-04-26 |  |  |  |  |  |  |  |  |  |  |  |  |  |  |  |  |  |  |  |  |  |  |  |  |  |  |
| PN661730 |  | CA17 ExtrBldgFl4 - Fabrication Gratings |  | 80d | 2011-01-27 A | 2011-04-16 A | EN681711 | 100% |  |  | TB26 - 2 - Manuf and Delivy |  |  | PN661730 | PN661730 | 860 | XNK | 17 |  | 200 | 200 |  | C |  |  | P | N | PN66 | 1730 | SS | LND |  |
| PN681730 |  | CA17 ExtrBldgFl4 - Transport Gratings to Site |  | 10d | 2011-04-17 A | 2011-04-26 A | PN661730 | 100% |  |  | TB26 - 2 - Manuf and Delivy |  |  | PN681730 | PN681730 | 860 | XNK | 17 |  | 200 | 200 |  | C |  |  | P | N | PN68 | 1730 | SS | LND |  |
| PN691730 |  | CA17 ExtrBldgFl4 - Gratings arrived at Site | milestone | 0d | 2011-04-26 A | 2011-04-26 A | PN681730 FF | 100% |  |  | TB26 - 2 - Manuf and Delivy |  |  | PN691730 | PN691730 | 860 | XNK | 17 |  | 200 | 200 |  | C |  |  | P | N | PN69 | 1730 | S | LND |  |
|  | H | **H HVAC** |  |  | 2011-11-24 | 2011-11-24 |  |  |  |  |  |  |  |  |  |  |  |  |  |  |  |  |  |  |  |  |  |  |  |  |  |  |
| P3H01SL |  | H01 HVAC Eqt. - 1stGoods arr. at Site CA17 (4th) | milestone | 0d | 2011-11-24 | 2011-11-24 | P3H01P SF+240d |  | 61d | 55d | TB26 - 2 - Manuf and Delivy |  |  | P3H01SL | P3H01SL | 860 | H01 | 17 | H01 | 000 | 200 | 400 | P | SC | L2 | P | H | PH19 | 1730 | hva_as | LND |  |
|  | U | **U Package Units** |  |  | 2010-11-25 | 2011-01-02 |  |  |  |  |  |  |  |  |  |  |  |  |  |  |  |  |  |  |  |  |  |  |  |  |  |  |
| P3U02S1 |  | PU02 Add. Feed Syst.- Goods arrived at site CA17 | milestone | 0d | 2010-11-25 A | 2010-11-25 A | P3U02G, HPU02 FF, P3U02N FF, E3U0270 | 100% |  |  | TB26 - 2 - Manuf and Delivy | 564,008 | 564,008 | P3U02S1 | P3U02S1 | 860 | PU02 | 17 | 2DC9820 | 200 | 200 | 400 | P | OWN | C2 | P | U | PU29 | 1730 | S | LND | DC |
| P3U10S2D |  | PU10 Convey. Syst. - Goods arr. at site 2nd LOT | milestone | 0d | 2011-01-02 A | 2011-01-02 A | P3U10N4 FF | 100% |  |  | TB26 - 2 - Manuf and Delivy |  |  | P3U10S2D | P3U10S2D | 860 | PU10 | 17 | 2DC8990 | 200 | 200 | 400 | P | OWN | C2 | P | U | PU19 | 1730 | S | LND | DC |
|  | B | **B Mechanical - Stationary Equipment** |  |  | 2011-10-08 | 2011-10-08 |  |  |  |  |  |  |  |  |  |  |  |  |  |  |  |  |  |  |  |  |  |  |  |  |  |  |
| P3A01S4 |  | A01 Drums/Small V. - Goods arrived at Site CA17 | milestone | 0d | 2011-10-08 | 2011-10-08 | P3A01N |  | 603.5d |  | TB26 - 2 - Manuf and Delivy |  |  | P3A01S4 | P3A01S4 | 860 | A01 | 17 | 2DD8530 | 200 | 200 | 400 | P | OWN | 0 | P | B | PB19 | 1730 | S | LND |  |
| P3A01S5 |  | A01 Drums/Small V. - Goods arrived at Site CA14 | milestone | 0d | 2011-10-08 | 2011-10-08 | P3A01N |  | -53d | 43d | TB26 - 2 - Manuf and Delivy |  |  | P3A01S5 | P3A01S5 | 860 | A01 | 17 | 2DD8530 | 200 | 200 | 400 | P | OWN | 0 | P | B | PB19 | 1730 | S | LND |  |
|  | 1736 | **1736 Extrusion Bldg 5th Floor +130,150m (+31,65m) - CA17** |  |  | 2010-11-25 | 2011-12-14 |  |  |  |  |  |  |  |  |  |  |  |  |  |  |  |  |  |  |  |  |  |  |  |  |  |  |
|  | N | **N Structural Steel** |  |  | 2011-01-27 | 2011-04-26 |  |  |  |  |  |  |  |  |  |  |  |  |  |  |  |  |  |  |  |  |  |  |  |  |  |  |
| PN661736 |  | CA17 ExtrBldgFl5 - Fabrication Gratings |  | 80d | 2011-01-27 A | 2011-04-16 A | EN681711 | 100% |  |  | TB26 - 2 - Manuf and Delivy |  |  | PN661736 | PN661736 | 860 | XNK | 17 |  | 200 | 200 |  | C |  |  | P | N | PN66 | 1736 | SS | LND |  |
| PN681736 |  | CA17 ExtrBldgFl5 - Transport Gratings to Site |  | 10d | 2011-04-17 A | 2011-04-26 A | PN661736 | 100% |  |  | TB26 - 2 - Manuf and Delivy |  |  | PN681736 | PN681736 | 860 | XNK | 17 |  | 200 | 200 |  | C |  |  | P | N | PN68 | 1736 | SS | LND |  |
| PN691736 |  | CA17 ExtrBldgFl5 - Gratings arrived at Site | milestone | 0d | 2011-04-26 A | 2011-04-26 A | PN681736 FF | 100% |  |  | TB26 - 2 - Manuf and Delivy |  |  | PN691736 | PN691736 | 860 | XNK | 17 |  | 200 | 200 |  | C |  |  | P | N | PN69 | 1736 | S | LND |  |

Notes:
- P3H01SK: UDF_Actictity Name (Russia): H01 Оборудование ОВКВ - Прибытие 1-й партии товара на площадку, CA17 (3)
- P3H01SL: UDF_Actictity Name (Russia): H01 Оборудование ОВКВ - Прибытие 1-й партии товара на площадку, CA17 (4)
- P3U02S1: Expenses: 900A 564008

| ID | WBS | Activity | Type | Duration | Start | Finish | Predecessors | Complete | Total float | Free float | Calendar | Resources | Cost | Actual cost | UDF_SAVE ACTID | UDF_SAVE ACT ID | Department | Type of Work | Constr. Area | Inquiry/Order No | PMT-Area | PMT-Schedule Org | PMT-Discipline | PMT-Phase | PMT-Respons. | Zeigen/n. Zeigen | WBS Phase | WBS Discipline | WBS Type of Work | WBS Objects | IMS | UPT | Pro Unit/DocCode | PMT-Doc. Type | TB26 Ressource Budget |
| --- | --- | --- | --- | --- | --- | --- | --- | --- | --- | --- | --- | --- | --- | --- | --- | --- | --- | --- | --- | --- | --- | --- | --- | --- | --- | --- | --- | --- | --- | --- | --- | --- | --- | --- | --- |
|  | H | **H HVAC** |  |  | 2011-12-14 | 2011-12-14 |  |  |  |  |  |  |  |  |  |  |  |  |  |  |  |  |  |  |  |  |  |  |  |  |  |  |  |  |  |
| P3H01SM |  | H01 HVAC Eqt. - 1stGoods arr. at Site CA17 (5th) | milestone | 0d | 2011-12-14 | 2011-12-14 | P3H01P SF+260d |  | 66d | 50d | TB26 - 2 - Manuf and Delivy |  |  |  | P3H01SM | P3H01SM | 860 | H01 | 17 | H01 | 000 | 200 | 400 | P | SC | L2 | P | H | PH19 | 1736 | hva_as | LND |  |  |  |
|  | U | **U Package Units** |  |  | 2010-11-25 | 2011-01-02 |  |  |  |  |  |  |  |  |  |  |  |  |  |  |  |  |  |  |  |  |  |  |  |  |  |  |  |  |  |
| P3U02S2 |  | PU02 Add. Feed Syst.- Goods arrived at site CA17 | milestone | 0d | 2010-11-25 A | 2010-11-25 A | P3U02N FF | 100% |  |  | TB26 - 2 - Manuf and Delivy |  |  |  | P3U02S2 | P3U02S2 | 860 | PU02 | 17 | 2DC9820 | 200 | 200 | 400 | P | OWN | C2 | P | U | PU29 | 1736 | S | LND | DC |  |  |
| P3U10S2E |  | PU10 Convey. Syst. - Goods arr. at site 2nd LOT | milestone | 0d | 2011-01-02 A | 2011-01-02 A | P3U10N4 FF | 100% |  |  | TB26 - 2 - Manuf and Delivy |  |  |  | P3U10S2E | P3U10S2E | 860 | PU10 | 17 | 2DC8990 | 200 | 200 | 400 | P | OWN | C2 | P | U | PU19 | 1736 | S | LND | DC |  |  |
|  | M | **M Mechanical - Rotating Equipment** |  |  | 2011-04-12 | 2011-04-12 |  |  |  |  |  |  |  |  |  |  |  |  |  |  |  |  |  |  |  |  |  |  |  |  |  |  |  |  |  |
| P3M01SB |  | M01 Extruder Pck. - Goods arrived at site | milestone | 0d | 2011-04-12 A | 2011-04-12 A | P3M01N, P3M01N5 | 100% |  |  | TB26 - 2 - Manuf and Delivy |  |  |  | P3M01SB | P3M01SB | 860 | M01 | 17 | 2DC8480 | 200 | 200 | 400 | P | OWN | C2 | P | M | PM39 | 1736 | S | LND | DC |  |  |
|  | 1740 | **1740 Extrusion Bldg 6th Floor +136,450m (+37,95m) - CA17** |  |  | 2010-11-25 | 2011-07-27 |  |  |  |  |  |  |  |  |  |  |  |  |  |  |  |  |  |  |  |  |  |  |  |  |  |  |  |  |  |
|  | N | **N Structural Steel** |  |  | 2011-01-27 | 2011-04-26 |  |  |  |  |  |  |  |  |  |  |  |  |  |  |  |  |  |  |  |  |  |  |  |  |  |  |  |  |  |
| PN661740 |  | CA17 ExtrBldgFl6 - Fabrication Gratings |  | 80d | 2011-01-27 A | 2011-04-16 A | EN681711, EN641711 | 100% |  |  | TB26 - 2 - Manuf and Delivy |  |  |  | PN661740 | PN661740 | 860 | XNK | 17 |  | 200 | 200 |  | C |  |  | P | N | PN66 | 1740 | SS | LND |  |  |  |
| PN681740 |  | CA17 ExtrBldgFl6 - Transport Gratings to Site |  | 10d | 2011-04-17 A | 2011-04-26 A | PN661740 | 100% |  |  | TB26 - 2 - Manuf and Delivy |  |  |  | PN681740 | PN681740 | 860 | XNK | 17 |  | 200 | 200 |  | C |  |  | P | N | PN68 | 1740 | SS | LND |  |  |  |
| PN691740 |  | CA17 ExtrBldgFl6 - Gratings arrived at Site | milestone | 0d | 2011-04-26 A | 2011-04-26 A | PN681740 FF | 100% |  |  | TB26 - 2 - Manuf and Delivy |  |  |  | PN691740 | PN691740 | 860 | XNK | 17 |  | 200 | 200 |  | C |  |  | P | N | PN69 | 1740 | S | LND |  |  |  |
|  | U | **U Package Units** |  |  | 2010-11-25 | 2011-07-27 |  |  |  |  |  |  |  |  |  |  |  |  |  |  |  |  |  |  |  |  |  |  |  |  |  |  |  |  |  |
| P3U02S3 |  | PU02 Add. Feed Syst.- Goods arrived at site CA17 | milestone | 0d | 2010-11-25 A | 2010-11-25 A | P3U02N FF | 100% |  |  | TB26 - 2 - Manuf and Delivy |  |  |  | P3U02S3 | P3U02S3 | 860 | PU02 | 17 | 2DC9820 | 200 | 200 | 400 | P | OWN | C2 | P | U | PU29 | 1740 | S | LND | DC |  |  |
| P3U22S1 |  | PU22 Vacuum System - Goods arrived at Site CA17 | milestone | 0d | 2011-07-27 A | 2011-07-27 A | HPU22 FF, P3U22G, P3U22N FF | 100% |  |  | TB26 - 2 - Manuf and Delivy |  | 87,770 | 87,770 | P3U22S1 | P3U22S1 | 860 | PU22 | 17 | 2DC9170 | 200 | 200 | 400 | P | OWN | 0 | P | U | PU99 | 1740 | S | LND |  |  |  |
|  | 1760 | **1760 Purge Bin Structure +189,245m (+90,75m) - CA17** |  |  | 2010-05-05 | 2012-02-25 |  |  |  |  |  |  |  |  |  |  |  |  |  |  |  |  |  |  |  |  |  |  |  |  |  |  |  |  |  |
|  | N | **N Structural Steel** |  |  | 2011-03-17 | 2011-08-19 |  |  |  |  |  |  |  |  |  |  |  |  |  |  |  |  |  |  |  |  |  |  |  |  |  |  |  |  |  |
| P3N02TE |  | CA17 PurgeColStr SK1703 - Vendor Procurement |  | 45d | 2011-03-17 A | 2011-04-30 A | EN27176010 | 100% |  |  | TB26 - 2 - Manuf and Delivy |  |  |  | P3N02TE | P3N02TE | 860 | N02T | 17 | N02T | 200 | 200 | 400 | P | Chel | 0 | P | N | PN25 | 1760 | SS | LND |  | DEL |  |
| P3N02SE |  | CA17 ExtrBldgEntrHall SK1702 - Vendor Procurement |  | 35d | 2011-03-22 A | 2011-04-25 A | EN27177010 | 100% |  |  | TB26 - 2 - Manuf and Delivy |  |  |  | P3N02SE | P3N02SE | 860 | N02S | 17 | N02S | 200 | 200 | 400 | P | Chel | 0 | P | N | PN25 | 1760 | SS | LND |  | DEL |  |
| PN661760 |  | CA17 PurgeColStr - Fabrication Gratings |  | 50d | 2011-04-05 A | 2011-05-25 A | EN641760, EN681760 | 100% |  |  | TB26 - 2 - Manuf and Delivy |  |  |  | PN661760 | PN661760 | 860 | XNK | 17 |  | 200 | 200 |  | C |  |  | P | N | PN66 | 1760 | SS | LND |  |  |  |
| P3N02SL |  | CA17 ExtrBldgEntrHall SK1702 - Vendor Fabrication |  | 45d | 2011-04-26 A | 2011-06-10 A | P3N02SE SS+20d, EN271770 SS+25d | 100% |  |  | TB26 - 2 - Manuf and Delivy |  |  |  | P3N02SL | P3N02SL | 860 | N02S | 17 | N02S | 200 | 200 | 400 | P | Chel | 0 | P | N | PN26 | 1760 | SS | LND |  | DEL |  |
| P3N02TL |  | CA17 PurgeColStr SK1703 - Vendor Fabrication |  | 79d | 2011-05-23 A | 2011-08-09 A | P3N02TE SS+30d, EN281760 SS+30d | 100% |  |  | TB26 - 2 - Manuf and Delivy |  |  |  | P3N02TL | P3N02TL | 860 | N02T | 17 | N02T | 200 | 200 | 400 | P | Chel | 0 | P | N | PN26 | 1760 | SS | LND |  | DEL |  |
| PN681760 |  | CA17 PurgeColStr - Transport Gratings to Site |  | 10d | 2011-05-26 A | 2011-06-04 A | PN661760 | 100% |  |  | TB26 - 2 - Manuf and Delivy |  |  |  | PN681760 | PN681760 | 860 | XNK | 17 |  | 200 | 200 |  | C |  |  | P | N | PN68 | 1760 | SS | LND |  |  |  |
| PN691760 |  | CA17 PurgeColStr - Gratings arrived at Site | milestone | 0d | 2011-06-04 A | 2011-06-04 A | PN681760 FF | 100% |  |  | TB26 - 2 - Manuf and Delivy |  |  |  | PN691760 | PN691760 | 860 | XNK | 17 |  | 200 | 200 |  | C |  |  | P | N | PN69 | 1760 | S | LND |  |  |  |
| P3N02SP |  | CA17 ExtrBldgEntrHall SK1702 - Transport to Site |  | 10d | 2011-06-11 A | 2011-06-20 A | P3N02SL | 100% |  |  | TB26 - 2 - Manuf and Delivy | Piperacks, Main Structures (Delivery) [320 t]; Ladders & Platforms (Delivery) [16 t] |  |  | P3N02SP | P3N02SP | 860 | N02S | 17 | N02S | 200 | 200 | 400 | P | Chel | 0 | P | N | PN28 | 1760 | SS | LND |  |  | 0,00 |
| P3N02SN |  | CA17 ExtrBldgEntrHall SK1702 - Goods arrived at Site | milestone | 0d | 2011-06-20 A | 2011-06-20 A | IMS-P-000080 (other project) FF, P3N02SP FF | 100% |  |  | TB26 - 2 - Manuf and Delivy |  |  |  | P3N02SN | P3N02SN | 860 | N02S | 17 | N02S | 200 | 200 | 400 | P | Chel | L2 | P | N | PN29 | 1760 | SS | LND |  |  |  |
| P3N02TP |  | CA17 PurgeColStr SK1703 - Transport to Site |  | 10d | 2011-08-10 A | 2011-08-19 A | P3N02TL | 100% |  |  | TB26 - 2 - Manuf and Delivy | Ladders & Platforms (Delivery) [37 t]; Piperacks, Main Structures (Delivery) [680 t] |  |  | P3N02TP | P3N02TP | 860 | N02T | 17 | N02T | 200 | 200 | 400 | P | Chel | 0 | P | N | PN28 | 1760 | SS | LND |  |  | 0,00 |
| P3N02TN |  | CA17 PurgeColStr SK1703 - Goods arrived at Site | milestone | 0d | 2011-08-19 A | 2011-08-19 A | P3N100 FF, P3N02TP FF | 100% |  |  | TB26 - 2 - Manuf and Delivy |  |  |  | P3N02TN | P3N02TN | 860 | N02T | 17 | N02T | 200 | 200 | 400 | P | Chel | L2 | P | N | PN29 | 1760 | M | LND |  |  |  |

Notes:
- P3H01SM: UDF_Actictity Name (Russia): H01 Оборудование ОВКВ - Прибытие 1-й партии товара на площадку, CA17 (5)
- P3U22S1: Expenses: 900A 87770
- P3N02SN: UDF_Actictity Name (Russia): CA17 Вестибюль здания экструзии SK1702 - Прибытие товара на площадку
- P3N02TN: UDF_Actictity Name (Russia): CA17 Конструкция продувочной колонны SK1703 - Прибытие товара на площадку

| ID | WBS | Activity | Type | Duration | Start | Finish | Predecessors | Complete | Remaining | Total float | Free float | Expected finish | Calendar | Resources | Cost | Actual cost | UDF_SAVE ACTID | UDF_SAVE ACT ID | Department | Type of Work | Constr. Area | Pro Unit/DocCode | Inquiry/Order No | PMT-Area | PMT-Schedule Org | PMT-Discipline | PMT-Phase | PMT-Respons. | Zeigen/n. Zeigen | WBS Phase | WBS Discipline | WBS Type of Work | WBS Objects | IMS | UPT | PMT-Doc. Type | TB26 Ressource Budget | UDF_Actictity Name (Russia) |
| --- | --- | --- | --- | --- | --- | --- | --- | --- | --- | --- | --- | --- | --- | --- | --- | --- | --- | --- | --- | --- | --- | --- | --- | --- | --- | --- | --- | --- | --- | --- | --- | --- | --- | --- | --- | --- | --- | --- |
|  | B | **B Mechanical - Stationary Equipment** |  |  | 2010-08-25 | 2011-03-30 |  |  |  |  |  |  |  |  |  |  |  |  |  |  |  |  |  |  |  |  |  |  |  |  |  |  |  |  |  |  |  |  |
| P3ALL2S |  | ALL2 Purge Columns - Goods arrived at site CA17 | milestone | 0d | 2010-08-25 A | 2010-08-25 A | HPBALL2 FF, P3ALL2G, P3ALL2N FF, P3ALL2N5 FF | 100% |  |  |  |  | TB26 - 2 - Manuf and Delivy |  | 132,172 | 132,172 | P3ALL2S | P3ALL2S | 860 | ALL2 | 17 | DC | 2DC8500 | 200 | 200 | 400 | P | OWN | C9 | P | B | PB49 | 1760 | S | LND |  |  |  |
| P3A08S |  | A08 Vent/Bag Filter - Goods arrived at site CA17 | milestone | 0d | 2011-03-30 A | 2011-03-30 A | P3A08G, P3A08N FF | 100% |  |  |  |  | TB26 - 2 - Manuf and Delivy |  | 121,400 | 121,400 | P3A08S | P3A08S | 860 | A08 | 17 | DC | 2DC8560 | 200 | 200 | 400 | P | OWN | C2 | P | B | PB89 | 1760 | S | LND |  |  |  |
|  | U | **U Package Units** |  |  | 2011-11-04 | 2011-11-04 |  |  |  |  |  |  |  |  |  |  |  |  |  |  |  |  |  |  |  |  |  |  |  |  |  |  |  |  |  |  |  |  |
| P3U05S |  | PU05 Big Bag L. Station - Goods arr.at Site CA17 | milestone | 0d | 2011-11-04 | 2011-11-04 | P3U05X, P3U05G, HPU05 FF, P3U05N FF |  |  | 576.5d |  |  | TB26 - 2 - Manuf and Delivy |  | 10,918 |  | P3U05S | P3U05S | 860 | PU05 | 17 |  | 2DC9640 | 200 | 200 | 400 | P | OWN | 0 | P | U | PU99 | 1760 | S | LND |  |  |  |
|  | M | **M Mechanical - Rotating Equipment** |  |  | 2011-06-21 | 2011-06-21 |  |  |  |  |  |  |  |  |  |  |  |  |  |  |  |  |  |  |  |  |  |  |  |  |  |  |  |  |  |  |  |  |
| P3M12S2 |  | M12 Rotary Feeder - Goods arrived at Site CA17 | milestone | 0d | 2011-06-21 A | 2011-06-21 A | P3M12N FF | 100% |  |  |  |  | TB26 - 2 - Manuf and Delivy |  |  |  | P3M12S2 | P3M12S2 | 860 | M12 | 17 |  | 2DC8940 | 200 | 200 | 400 | P | OWN | 0 | P | M | PM98 | 1760 | S | LND |  |  |  |
|  | E | **E Electrical** |  |  | 2010-05-05 | 2011-11-15 |  |  |  |  |  |  |  |  |  |  |  |  |  |  |  |  |  |  |  |  |  |  |  |  |  |  |  |  |  |  |  |  |
| P3E17A |  | E17 Aviation Lights - Prepare/Issue RFQ |  | 3d | 2010-05-05 A | 2010-05-07 A | E3E1710 | 100% |  |  |  |  |  |  |  |  | P3E17A | P3E17A | 87G | E17 | 17 |  | 2EB6130 | 200 | 200 | 400 | P | LND | 0 | P | E | EE44 | 1760 | ELE | LND | DEV |  |  |
| P3E17B |  | E17 Aviation Lights - RFQ issued | milestone | 0d | 2010-05-07 A | 2010-05-07 A | P3E17A | 100% |  |  |  |  |  |  |  |  | P3E17B | P3E17B | 87G | E17 | 17 |  | 2EB6130 | 200 | 200 | 400 | P | LND | 0 | P | E | EE44 | 1760 | ELE | LND | DEV |  |  |
| P3E17C |  | E17 Aviation Lights - Eval./Negotiation |  | 110d | 2010-07-14 A | 2010-12-15 A | E3E1720 FF, P3E17B | 100% |  |  |  |  |  |  |  |  | P3E17C | P3E17C | 87G | E17 | 17 |  | 2EB6130 | 200 | 200 | 400 | P | LND | 0 | P | E | EE44 | 1760 | ELE | LND |  |  |  |
| P3E17D |  | E17 Aviation Lights - PO issued | milestone | 0d | 2010-12-15 A | 2010-12-15 A | P3E17C FF, E3E1720 | 100% |  |  |  |  |  |  |  |  | P3E17D | P3E17D | 87G | E17 | 17 |  | 2EB6130 | 200 | 200 | 400 | P | LND | 0 | P | E | EE44 | 1760 | ELE | LND |  |  |  |
| P3E17L |  | E17 Aviation Lights - Lead Time/Fabrication |  | 316d | 2010-12-16 A | 2011-10-31 | P3E17D |  | 61d | 565.5d | 0d | 2011-10-31 | TB26 - 2 - Manuf and Delivy |  |  |  | P3E17L | P3E17L | 87G | E17 | 17 |  | 2EB6130 | 200 | 200 | 400 | P | LND | 0 | P | E | EE44 | 1760 | ELE | LND | DEL |  |  |
| P3E17X |  | E17 Aviation Lights - Final Inspection | milestone | 0d | 2011-10-22 | 2011-10-22 | P3E17L FF-10d |  |  | 580.5d | 15d |  | TB26 - 2 - Manuf and Delivy |  |  |  | P3E17X | P3E17X | 87G | E17 | 17 |  | 2EB6130 | 200 | 200 | 400 | P | LND | 0 | P | E | EE44 | 1760 | ELE | LND |  |  |  |
| P3E17M |  | E17 Aviation Lights - Goods deliv. FOB | milestone | 0d | 2011-11-05 | 2011-11-05 | P3E17X FF, P3E17L FF+5d |  |  | 565.5d | 0d |  | TB26 - 2 - Manuf and Delivy |  |  |  | P3E17M | P3E17M | 87G | E17 | 17 |  | 2EB6130 | 200 | 200 | 400 | P | LND | 0 | P | E | EE44 | 1760 | ELE | LND |  |  |  |
| P3E17N |  | E17 Aviation Lights - Transport to Site |  | 10d | 2011-11-06 | 2011-11-15 | P3E17M |  |  | 565.5d | 0d |  | TB26 - 2 - Manuf and Delivy |  |  |  | P3E17N | P3E17N | 87G | E17 | 17 |  | 2EB6130 | 200 | 200 | 400 | P | LND | 0 | P | E | EE44 | 1760 | ELE | LND |  |  |  |
| P3E17S |  | E17 Aviation Lights - Goods arr. at Site CA17 | milestone | 0d | 2011-11-15 | 2011-11-15 | P3E17N |  |  | 565.5d |  |  | TB26 - 2 - Manuf and Delivy |  |  |  | P3E17S | P3E17S | 87G | E17 | 17 |  | 2EB6130 | 200 | 200 | 400 | P | LND | 0 | P | E | EE44 | 1760 | IT | LND |  |  |  |
|  | J | **J Instrumentation** |  |  | 2012-02-25 | 2012-02-25 |  |  |  |  |  |  |  |  |  |  |  |  |  |  |  |  |  |  |  |  |  |  |  |  |  |  |  |  |  |  |  |  |
| P3J03S3 |  | J03 Nuclear L. Meas.- Goods arrived at Site CA17 | milestone | 0d | 2012-02-25 | 2012-02-25 | IMS-P-000160 (other project), P3J03N FF |  |  | 38d | 103d |  | TB26 - 2 - Manuf and Delivy |  |  |  | P3J03S3 | P3J03S3 | 860 | J03 | 17 |  | 2JD7540 | 200 | 200 | 400 | P | OWN | 0 | P | J | PJ39 | 1760 | IT | LND |  |  |  |
| P3J03S4 |  | J03 Nuclear L. Meas.- Radiactive Sources DDU Tobolsk | milestone | 0d | 2012-02-25 | 2012-02-25 | HPJJ03 FF, P3J03N, P3J100 FF |  |  | 180d | 277.5d |  | TB26 - 2 - Manuf and Delivy |  |  |  | P3J03S4 | P3J03S4 | 860 | J03 | 17 |  | 2JD7540 | 200 | 200 | 400 | P | OWN | 0 | P | J | PJ39 | 1760 | IT | LND |  |  |  |
|  | 31 | **31 CA31 - Storage / Packaging and Shipping Building** |  |  | 2008-08-01 | 2011-11-24 |  |  |  |  |  |  |  |  |  |  |  |  |  |  |  |  |  |  |  |  |  |  |  |  |  |  |  |  |  |  |  |  |
|  | 3110 | **3110 Silo Structure - CA31** |  |  | 2008-08-01 | 2011-09-25 |  |  |  |  |  |  |  |  |  |  |  |  |  |  |  |  |  |  |  |  |  |  |  |  |  |  |  |  |  |  |  |  |
|  | N | **N Structural Steel** |  |  | 2010-10-18 | 2011-04-25 |  |  |  |  |  |  |  |  |  |  |  |  |  |  |  |  |  |  |  |  |  |  |  |  |  |  |  |  |  |  |  |  |
| P3N02YE |  | CA31 SiloStruc SK3101 - Vendor Procurement |  | 40d | 2010-10-18 A | 2010-11-26 A | EN27311010 | 100% |  |  |  |  | TB26 - 2 - Manuf and Delivy |  |  |  | P3N02YE | P3N02YE | 860 | N02Y | 31 |  | N02Y | 200 | 200 | 400 | P | Chel | 0 | P | N | PN25 | 3110 | SS | LND | DEL |  |  |
| P3N01S |  | N01 Structural Steel Fab - 1st Goods arrived at Site | milestone | 0d | 2010-12-03 A | 2010-12-03 A | P3N01N FF | 100% |  |  |  |  | TB26 - 2 - Manuf and Delivy |  |  |  | P3N01S | P3N01S | 860 | N01 | 31 |  | 2M00020 | 200 | 200 | 400 | P | OWN | 0 | P | N | PM19 | 3110 | SS | LND |  |  |  |
| PN663110 |  | CA31 SiloStruc SK3101 - Fabrication Gratings |  | 103d | 2010-12-10 A | 2011-03-25 A | EN683110 | 100% |  |  |  |  | TB26 - 2 - Manuf and Delivy |  |  |  | PN663110 | PN663110 | 860 | N02Y | 31 |  | N02Y | 200 | 200 |  | C | OWN |  | P | N | PN66 | 3110 | SS | LND |  |  |  |
| P3N02YL |  | CA31 SiloStruc SK3101 - Vendor Fabrication |  | 96d | 2010-12-17 A | 2011-03-25 A | P3N02YE SS+20d, EN283110 SS+35d | 100% |  |  |  |  | TB26 - 2 - Manuf and Delivy |  |  |  | P3N02YL | P3N02YL | 860 | N02Y | 31 |  | N02Y | 200 | 200 | 400 | P | Chel | 0 | P | N | PN26 | 3110 | SS | LND | DEL |  |  |
| P3N02#L |  | CA31 Staircase SK3105 - Vendor Fabrication |  | 64d | 2010-12-28 A | 2011-03-02 A | EN283115 SS+20d, P3N02#E SS+20d | 100% |  |  |  |  | TB26 - 2 - Manuf and Delivy |  |  |  | P3N02#L | P3N02#L | 860 | N02# | 31 |  | N02# | 200 | 200 | 400 | P | Chel | 0 | P | N | PN26 | 3110 | SS | LND | DEL |  |  |
| PN663115 |  | CA31 Staircase SK3105 - Fabrication Gratings |  | 60d | 2011-01-26 A | 2011-03-26 A | EN683115 FS+20d | 100% |  |  |  |  | TB26 - 2 - Manuf and Delivy |  |  |  | PN663115 | PN663115 | 860 | N02# | 31 |  | N02# | 200 | 200 |  | C | OWN |  | P | N | PN66 | 3110 | SS | LND |  |  |  |
| P3N02YP |  | CA31 SiloStruc SK3101 - Transport to Site |  | 69d | 2011-02-16 A | 2011-04-25 A | P3N02YL FS-15d | 100% |  |  |  |  | TB26 - 2 - Manuf and Delivy | Piperacks, Main Structures (Delivery) [679 t]; Ladders & Platforms (Delivery) [20 t] |  |  | P3N02YP | P3N02YP | 860 | N02Y | 31 |  | N02Y | 200 | 200 | 400 | P | Chel | 0 | P | N | PN28 | 3110 | SS | LND |  | 0,00 |  |
| PN683110 |  | CA31 SiloStruc SK3101 - Transport Gratings to Site |  | 69d | 2011-02-16 A | 2011-04-25 A | PN663110 FS-15d | 100% |  |  |  |  | TB26 - 2 - Manuf and Delivy |  |  |  | PN683110 | PN683110 | 860 | N02Y | 31 |  | N02Y | 200 | 200 |  | C | OWN |  | P | N | PN68 | 3110 | SS | LND |  |  |  |
| PN693110 |  | CA31 SiloStruc SK3101 - Gratings arrived at Site (1st Lot's) | milestone | 0d | 2011-03-01 A | 2011-03-01 A | PN683110 SF+14d | 100% |  |  |  |  | TB26 - 2 - Manuf and Delivy |  |  |  | PN693110 | PN693110 | 860 | N02Y | 31 |  | N02Y | 200 | 200 |  | C | OWN |  | P | N | PN69 | 3110 | S | LND |  |  |  |
| P3N02#P |  | CA31 Staircase SK3105 - Transport to Site |  | 10d | 2011-03-03 A | 2011-03-12 A | P3N02#L | 100% |  |  |  |  | TB26 - 2 - Manuf and Delivy | Piperacks, Main Structures (Delivery) [169 t]; Ladders & Platforms (Delivery) [21 t] |  |  | P3N02#P | P3N02#P | 860 | N02# | 31 |  | N02# | 200 | 200 | 400 | P | Chel | 0 | P | N | PN28 | 3110 | SS | LND |  | 0,00 |  |
| P3N02#N |  | CA31 Staircase SK3105 - Goods arr at Site | milestone | 0d | 2011-03-12 A | 2011-03-12 A | P3N02#P FF | 100% |  |  |  |  | TB26 - 2 - Manuf and Delivy |  |  |  | P3N02#N | P3N02#N | 860 | N02# | 31 |  | N02# | 200 | 200 | 400 | P | Chel | L2 | P | N | PN29 | 3110 | SS | LND |  |  | CA31 ..... силосов SK3105 - Прибытие товара на площадку |
| PN683115 |  | CA31 Staircase SK3105 - Transport Gratings to Site |  | 15d | 2011-03-27 A | 2011-04-10 A | PN663115, P3N02#P SS | 100% |  |  |  |  | TB26 - 2 - Manuf and Delivy |  |  |  | PN683115 | PN683115 | 860 | N02# | 31 |  | N02# | 200 | 200 |  | C | OWN |  | P | N | PN68 | 3110 | SS | LND |  |  |  |
| PN693115 |  | CA31 Staircase SK3105 - Gratings arrived at Site | milestone | 0d | 2011-04-10 A | 2011-04-10 A | PN683115 FF | 100% |  |  |  |  | TB26 - 2 - Manuf and Delivy |  |  |  | PN693115 | PN693115 | 860 | N02# | 31 |  | N02# | 200 | 200 |  | C | OWN |  | P | N | PN69 | 3110 | S | LND |  |  |  |

Notes:
- P3ALL2S: Expenses: 900A 132172
- P3A08S: Expenses: 900A 121400
- P3U05S: Expenses: 900A 10918
- P3J03S3: P3 Activity Log Info: as late as possible to install just in / time

| ID | WBS | Activity | Type | Duration | Start | Finish | Predecessors | Complete | Total float | Free float | Calendar | Resources | Cost | Actual cost | UDF_SAVE ACTID | UDF_SAVE ACT ID | Department | Type of Work | Constr. Area | Inquiry/Order No | PMT-Area | PMT-Schedule Org | PMT-Discipline | PMT-Phase | PMT-Respons. | Zeigen/n. Zeigen | WBS Phase | WBS Discipline | WBS Type of Work | WBS Objects | IMS | UPT | Pro Unit/DocCode | PMT-Doc. Type | TB26 Ressource Budget |
| --- | --- | --- | --- | --- | --- | --- | --- | --- | --- | --- | --- | --- | --- | --- | --- | --- | --- | --- | --- | --- | --- | --- | --- | --- | --- | --- | --- | --- | --- | --- | --- | --- | --- | --- | --- |
|  | H | **H HVAC** |  |  | 2011-05-03 | 2011-05-03 |  |  |  |  |  |  |  |  |  |  |  |  |  |  |  |  |  |  |  |  |  |  |  |  |  |  |  |  |  |
| P3H01SQ |  | H01 HVAC Eqt. - 1stGoods arr. at Site CA31 Silo | milestone | 0d | 2011-05-03 A | 2011-05-03 A | P3H01P SF+35d | 100% |  |  | TB26 - 2 - Manuf and Delivy |  |  |  | P3H01SQ | P3H01SQ | 860 | H01 | 31 | H01 | 000 | 200 | 400 | P | SC | L2 | P | H | PH19 | 3110 | hva_as | LND |  |  |  |
|  | U | **U Package Units** |  |  | 2010-10-22 | 2011-07-28 |  |  |  |  |  |  |  |  |  |  |  |  |  |  |  |  |  |  |  |  |  |  |  |  |  |  |  |  |  |
| P3U10S1 |  | PU10 Convey. Syst. - Goods arr. at site 1st LOT | milestone | 0d | 2010-10-22 A | 2010-10-22 A | HPU10 FF, P3U10N1 FF, P3U10N1G | 100% |  |  | TB26 - 2 - Manuf and Delivy |  | 935,567 | 935,567 | P3U10S1 | P3U10S1 | 860 | PU10 | 31 | 2DC8990 | 200 | 200 | 400 | P | OWN | C2 | P | U | PU19 | 3110 | S | LND | DC |  |  |
| P3U06S |  | PU06 Bagging System - Goods arrived at Site CA31 | milestone | 0d | 2011-07-28 A | 2011-07-28 A | P3U06G, IMS-P-000050 (other project) FF, HPU06 FF, P3U06N FF | 100% |  |  | TB26 - 2 - Manuf and Delivy |  | 108,885 | 108,885 | P3U06S | P3U06S | 860 | PU06 | 31 | 2DC9010 | 200 | 200 | 400 | P | OWN | C2 | P | U | PU38 | 3110 | S | LND | DC |  |  |
|  | B | **B Mechanical - Stationary Equipment** |  |  | 2008-08-01 | 2011-09-25 |  |  |  |  |  |  |  |  |  |  |  |  |  |  |  |  |  |  |  |  |  |  |  |  |  |  |  |  |  |
| F2840 |  | P.O. Silo storage | milestone | 0d | 2008-08-01 A | 2008-08-01 A | P3ALL4D1, F2830 SS+62d | 100% |  |  |  |  |  |  | F2840 | F2840 | 860 |  | 31 | 999 | 200 | 200 |  | P | LND |  | P | B | 0000 | 3110 | 1 | LND | 90 |  |  |
| P3ALL4S1 |  | ALL4 Silo's - Goods arrived at Site 1st LOT CA31 | milestone | 0d | 2010-08-23 A | 2010-08-23 A | HPBALL4 FF, P3ALL4N3 FF, P3ALL4G, P3ALL4N1 FF | 100% |  |  | TB26 - 2 - Manuf and Delivy |  | 387,290 | 387,290 | P3ALL4S1 | P3ALL4S1 | 860 | ALL4 | 31 | 2DC9000 | 200 | 200 | 400 | P | OWN | C2 | P | B | PB69 | 3110 | S | LND | DC |  |  |
| P3ALL4S2 |  | ALL4 Silo's - Goods arrived at Site 2nd LOT CA31 | milestone | 0d | 2010-08-23 A | 2010-08-23 A | P3ALL4N3 FF, P3ALL4N2 FF | 100% |  |  | TB26 - 2 - Manuf and Delivy |  |  |  | P3ALL4S2 | P3ALL4S2 | 860 | ALL4 | 31 | 2DC9000 | 200 | 200 | 400 | P | OWN | C2 | P | B | PB69 | 3110 | S | LND | DC |  |  |
| P3A13S3B |  | A13 Scales - Goods arr. at Site CA31 (MI-31201) | milestone | 0d | 2010-11-30 A | 2010-11-30 A | P3A13N FF | 100% |  |  | TB26 - 2 - Manuf and Delivy |  |  |  | P3A13S3B | P3A13S3B | 860 | A13 | 31 | 2DC9060 | 200 | 200 | 400 | P | OWN | 0 | P | B | PB99 | 3110 | S | LND |  |  |  |
| P3A06AS3 |  | A06A Electrical Heater - Goods arr. at Site CA31 | milestone | 0d | 2011-06-10 A | 2011-06-10 A | P3A06AG, P3A06AN FF | 100% |  |  | TB26 - 2 - Manuf and Delivy |  |  |  | P3A06AS3 | P3A06AS3 | 860 | A06A | 31 | 2DC9080 | 200 | 200 | 400 | P | OWN | 0 | P | B | PB29 | 3110 | S | LND |  |  |  |
| P3A12S2 |  | A12 Overhead Cranes - Goods arrived at Site CA31 | milestone | 0d | 2011-09-25 | 2011-09-25 | P3A12N |  | 44d | 0d | TB26 - 2 - Manuf and Delivy |  |  |  | P3A12S2 | P3A12S2 | 860 | A12 | 31 | 2KB4740 | 200 | 200 | 400 | P | OWN | 0 | P | B | PB99 | 3110 | S | LND |  |  |  |
|  | E | **E Electrical** |  |  | 2010-12-04 | 2011-06-25 |  |  |  |  |  |  |  |  |  |  |  |  |  |  |  |  |  |  |  |  |  |  |  |  |  |  |  |  |  |
| P3E02S2 |  | E02 PowerTransformer - Goods arr. at SiteCA31 | milestone | 0d | 2010-12-04 A | 2010-12-04 A | P3E02N, P3E02G | 100% |  |  | TB26 - 2 - Manuf and Delivy |  |  |  | P3E02S2 | P3E02S2 | 860 | E02 | 31 | 2EB5620 | 200 | 200 | 400 | P | OWN | 0 | P | E | EE20 | 3110 | ELE | LND |  |  |  |
| P3E01BS2 |  | E01B LV-SWG/MCC/Softstarter/FQ - Goods arr. at SiteCA31 | milestone | 0d | 2011-06-25 A | 2011-06-25 A | P3E01BG, P3E01BN | 100% |  |  | TB26 - 2 - Manuf and Delivy |  | 547,545 | 547,545 | P3E01BS2 | P3E01BS2 | 860 | E01B | 31 | 2EB5630 | 200 | 200 | 400 | P | OWN | 0 | P | E | EE20 | 3110 | ELE | LND |  |  |  |
|  | J | **J Instrumentation** |  |  | 2010-11-30 | 2010-11-30 |  |  |  |  |  |  |  |  |  |  |  |  |  |  |  |  |  |  |  |  |  |  |  |  |  |  |  |  |  |
| P3J18S |  | J18 Weighing for Vessels - Goods arrived at Site | milestone | 0d | 2010-11-30 A | 2010-11-30 A | P3J18G, P3J18N FF, HPJJ18 FF | 100% |  |  | TB26 - 2 - Manuf and Delivy |  | 3,367 | 3,367 | P3J18S | P3J18S | 860 | J18 | 31 | J18 | 200 | 200 | 400 | P | OWN | 0 | P | J | PJ39 | 3110 | S | LND |  |  |  |
|  | 3120 | **3120 Blower Room & Truck Inliner Loading - CA31** |  |  | 2010-10-22 | 2011-10-15 |  |  |  |  |  |  |  |  |  |  |  |  |  |  |  |  |  |  |  |  |  |  |  |  |  |  |  |  |  |
|  | N | **N Structural Steel** |  |  | 2011-02-16 | 2011-04-30 |  |  |  |  |  |  |  |  |  |  |  |  |  |  |  |  |  |  |  |  |  |  |  |  |  |  |  |  |  |
| P3N02ZE |  | CA31 Blower Sec SK3104 - Vendor Procurement |  | 40d | 2011-02-16 A | 2011-03-27 A | EN27312010 FS+15d | 100% |  |  | TB26 - 2 - Manuf and Delivy |  |  |  | P3N02ZE | P3N02ZE | 860 | N02Z | 31 | N02Z | 200 | 200 | 400 | P | Chel | 0 | P | N | PN25 | 3120 | SS | LND |  | DEL |  |
| P3N02YN |  | CA31 SiloStruc SK3101 - Goods arrived at Site (1st Lot's) | milestone | 0d | 2011-03-01 A | 2011-03-01 A | P3N02YP SF+14d | 100% |  |  | TB26 - 2 - Manuf and Delivy |  |  |  | P3N02YN | P3N02YN | 860 | N02Y | 31 | N02Y | 200 | 200 | 400 | P | Chel |  | P | N | PN29 | 3120 | SS | LND |  |  |  |
| PN663120 |  | CA31 Blower Sec SK3104 - Fabrication Gratings |  | 48d | 2011-03-04 A | 2011-04-20 A | EN643120 FF, EN683120 | 100% |  |  | TB26 - 2 - Manuf and Delivy |  |  |  | PN663120 | PN663120 | 860 | N02Z | 31 | N02Z | 200 | 200 |  | C | OWN |  | P | N | PN66 | 3120 | SS | LND |  |  |  |
| P3N02ZL |  | CA31 Blower Sec SK3104 - Vendor Fabrication |  | 41d | 2011-03-11 A | 2011-04-20 A | EN283120 SS+35d, P3N02ZE SS+15d | 100% |  |  | TB26 - 2 - Manuf and Delivy |  |  |  | P3N02ZL | P3N02ZL | 860 | N02Z | 31 | N02Z | 200 | 200 | 400 | P | Chel | 0 | P | N | PN26 | 3120 | SS | LND |  | DEL |  |
| P3N02ZP |  | CA31 Blower Sec SK3104 - Transport to Site |  | 10d | 2011-04-21 A | 2011-04-30 A | P3N02ZL | 100% |  |  | TB26 - 2 - Manuf and Delivy | Ladders & Platforms (Delivery) [77 t]; Piperacks, Main Structures (Delivery) [53 t] |  |  | P3N02ZP | P3N02ZP | 860 | N02Z | 31 | N02Z | 200 | 200 | 400 | P | Chel | 0 | P | N | PN28 | 3120 | SS | LND |  |  | 0,00 |
| PN683120 |  | CA31 Blower Sec SK3104 - Transport Gratings to Site |  | 10d | 2011-04-21 A | 2011-04-30 A | PN663120, P3N02ZP SS | 100% |  |  | TB26 - 2 - Manuf and Delivy |  |  |  | PN683120 | PN683120 | 860 | N02Z | 31 | N02Z | 200 | 200 |  | C | OWN |  | P | N | PN68 | 3120 | SS | LND |  |  |  |
| P3N02ZN |  | CA31 Blower Sec SK3104 - Goods arrived at Site | milestone | 0d | 2011-04-30 A | 2011-04-30 A | P3N02ZP FF | 100% |  |  | TB26 - 2 - Manuf and Delivy |  |  |  | P3N02ZN | P3N02ZN | 860 | N02Z | 31 | N02Z | 200 | 200 | 400 | P | Chel | L2 | P | N | PN29 | 3120 | SS | LND |  |  |  |
| PN693120 |  | CA31 Blower Sec SK3104 - Gratings arrived at Site | milestone | 0d | 2011-04-30 A | 2011-04-30 A | PN683120 FF | 100% |  |  | TB26 - 2 - Manuf and Delivy |  |  |  | PN693120 | PN693120 | 860 | N02Z | 31 | N02Z | 200 | 200 |  | C | OWN |  | P | N | PN69 | 3120 | S | LND |  |  |  |

Notes:
- P3H01SQ: UDF_Actictity Name (Russia): H01 Оборудование ОВКВ - Прибытие 1-й партии товара на площадку, CA31 Силосы
- P3U10S1: Expenses: 900A 935567
- P3U06S: Expenses: 900A 108885
- P3ALL4S1: Expenses: 900A 387290
- P3E01BS2: Expenses: 900A 547545
- P3J18S: Expenses: 900A 3367
- P3N02YN: UDF_Actictity Name (Russia): CA31 Конструкция силосов SK3101 - Прибытие товара на площадку
- P3N02ZN: UDF_Actictity Name (Russia): CA31 Секция нагнетателей SK3104 - Прибытие товара на площадку

| ID | WBS | Activity | Type | Duration | Start | Finish | Predecessors | Complete | Total float | Free float | Calendar | Resources | Cost | Actual cost | UDF_SAVE ACTID | UDF_SAVE ACT ID | Department | Type of Work | Constr. Area | Inquiry/Order No | PMT-Area | PMT-Schedule Org | PMT-Discipline | PMT-Phase | PMT-Respons. | Zeigen/n. Zeigen | WBS Phase | WBS Discipline | WBS Type of Work | WBS Objects | IMS | UPT | Pro Unit/DocCode | PMT-Doc. Type | TB26 Ressource Budget |
| --- | --- | --- | --- | --- | --- | --- | --- | --- | --- | --- | --- | --- | --- | --- | --- | --- | --- | --- | --- | --- | --- | --- | --- | --- | --- | --- | --- | --- | --- | --- | --- | --- | --- | --- | --- |
|  | H | **H HVAC** |  |  | 2011-10-15 | 2011-10-15 |  |  |  |  |  |  |  |  |  |  |  |  |  |  |  |  |  |  |  |  |  |  |  |  |  |  |  |  |  |
| P3H01SR |  | H01 HVAC Eqt. - 1stGood arr. at Site CA31 Blower | milestone | 0d | 2011-10-15 | 2011-10-15 | P3H01P SF+200d |  | 145d | 41d | TB26 - 2 - Manuf and Delivy |  |  |  | P3H01SR | P3H01SR | 860 | H01 | 31 | H01 | 000 | 200 | 400 | P | SC | L2 | P | H | PH19 | 3120 | hva_as | LND |  |  |  |
|  | U | **U Package Units** |  |  | 2010-10-22 | 2011-01-23 |  |  |  |  |  |  |  |  |  |  |  |  |  |  |  |  |  |  |  |  |  |  |  |  |  |  |  |  |  |
| P3U10S1A |  | PU10 Convey. Syst. - Goods arr. at site 1st LOT | milestone | 0d | 2010-10-22 A | 2010-10-22 A | P3U10N1 | 100% |  |  | TB26 - 2 - Manuf and Delivy |  |  |  | P3U10S1A | P3U10S1A | 860 | PU10 | 31 | 2DC8990 | 200 | 200 | 400 | P | OWN | C2 | P | U | PU19 | 3120 | S | LND | DC |  |  |
| P3U10S3 |  | PU10 Convey. Syst. - Goods arr. at site 3rd LOT | milestone | 0d | 2011-01-23 A | 2011-01-23 A | E3U1070, P3U10N3 FF | 100% |  |  | TB26 - 2 - Manuf and Delivy |  | 311,856 | 311,856 | P3U10S3 | P3U10S3 | 860 | PU10 | 31 | 2DC8990 | 200 | 200 | 400 | P | OWN | C2 | P | U | PU19 | 3120 | S | LND | DC |  |  |
|  | B | **B Mechanical - Stationary Equipment** |  |  | 2010-11-30 | 2010-11-30 |  |  |  |  |  |  |  |  |  |  |  |  |  |  |  |  |  |  |  |  |  |  |  |  |  |  |  |  |  |
| P3A13S3A |  | A13 Scales - Goods arr. at Site CA31 (MI-21501) | milestone | 0d | 2010-11-30 A | 2010-11-30 A | P3A13N FF | 100% |  |  | TB26 - 2 - Manuf and Delivy |  |  |  | P3A13S3A | P3A13S3A | 860 | A13 | 31 | 2DC9060 | 200 | 200 | 400 | P | OWN | 0 | P | B | PB99 | 3120 | S | LND |  |  |  |
|  | 3130 | **3130 Service Area - CA31** |  |  | 2011-01-29 | 2011-11-24 |  |  |  |  |  |  |  |  |  |  |  |  |  |  |  |  |  |  |  |  |  |  |  |  |  |  |  |  |  |
|  | N | **N Structural Steel** |  |  | 2011-01-29 | 2011-04-25 |  |  |  |  |  |  |  |  |  |  |  |  |  |  |  |  |  |  |  |  |  |  |  |  |  |  |  |  |  |
| P3N02ДE |  | CA31 Service Area SK3103 - Vendor Procurement |  | 40d | 2011-01-29 A | 2011-03-09 A | EN27313010 | 100% |  |  | TB26 - 2 - Manuf and Delivy |  |  |  | P3N02ДE | P3N02ДE | 860 | N02Д | 31 | N02Д | 200 | 200 | 400 | P | Chel | 0 | P | N | PN25 | 3130 | SS | LND |  | DEL |  |
| P3N02ДL |  | CA31 Service Area SK3103 - Vendor Fabrication |  | 47d | 2011-03-05 A | 2011-04-20 A | EN283130 SS+25d, P3N02ДE SS+20d | 100% |  |  | TB26 - 2 - Manuf and Delivy |  |  |  | P3N02ДL | P3N02ДL | 860 | N02Д | 31 | N02Д | 200 | 200 | 400 | P | Chel | 0 | P | N | PN26 | 3130 | SS | LND |  | DEL |  |
| PN663130 |  | CA31 Service Area SK3103 - Fabrication Gratings |  | 40d | 2011-03-12 A | 2011-04-20 A | EN643130 FF, EN683130 | 100% |  |  | TB26 - 2 - Manuf and Delivy |  |  |  | PN663130 | PN663130 | 860 | N02Д | 31 | N02Д | 200 | 200 |  | C | OWN |  | P | N | PN66 | 3130 | SS | LND |  |  |  |
| P3N02ДP |  | CA31 Service Area SK3103 - Transport to Site |  | 5d | 2011-04-21 A | 2011-04-25 A | P3N02ДL | 100% |  |  | TB26 - 2 - Manuf and Delivy | Ladders & Platforms (Delivery) [55 t]; Piperacks, Main Structures (Delivery) [76 t] |  |  | P3N02ДP | P3N02ДP | 860 | N02Д | 31 | N02Д | 200 | 200 | 400 | P | Chel | 0 | P | N | PN28 | 3130 | SS | LND |  |  | 0,00 |
| PN683130 |  | CA31 Service Area SK3103 - Transport Gratings to Site |  | 5d | 2011-04-21 A | 2011-04-25 A | PN663130, P3N02ДP SS | 100% |  |  | TB26 - 2 - Manuf and Delivy |  |  |  | PN683130 | PN683130 | 860 | N02Д | 31 | N02Д | 200 | 200 |  | C | OWN |  | P | N | PN68 | 3130 | SS | LND |  |  |  |
| P3N02ДN |  | CA31 Service Area SK3103 - Goods arrived at Site | milestone | 0d | 2011-04-25 A | 2011-04-25 A | P3N02ДP FF | 100% |  |  | TB26 - 2 - Manuf and Delivy |  |  |  | P3N02ДN | P3N02ДN | 860 | N02Д | 31 | N02Д | 200 | 200 | 400 | P | Chel | L2 | P | N | PN29 | 3130 | M | LND |  |  |  |
| PN693130 |  | CA31 Service Area SK3103 - Gratings arrived at Site | milestone | 0d | 2011-04-25 A | 2011-04-25 A | PN683130 FF | 100% |  |  | TB26 - 2 - Manuf and Delivy |  |  |  | PN693130 | PN693130 | 860 | N02Д | 31 | N02Д | 200 | 200 |  | C | OWN |  | P | N | PN69 | 3130 | S | LND |  |  |  |
|  | H | **H HVAC** |  |  | 2011-11-24 | 2011-11-24 |  |  |  |  |  |  |  |  |  |  |  |  |  |  |  |  |  |  |  |  |  |  |  |  |  |  |  |  |  |
| P3H01SS |  | H01 HVAC Eqt. - 1stGood arr. at Site CA31 Office | milestone | 0d | 2011-11-24 | 2011-11-24 | P3H01P SF+240d |  | -132d | 50d | TB26 - 2 - Manuf and Delivy |  |  |  | P3H01SS | P3H01SS | 860 | H01 | 31 | H01 | 000 | 200 | 400 | P | SC | L2 | P | H | PH19 | 3130 | hva_as | LND |  |  |  |
|  | E | **E Electrical** |  |  | 2011-05-25 | 2011-05-25 |  |  |  |  |  |  |  |  |  |  |  |  |  |  |  |  |  |  |  |  |  |  |  |  |  |  |  |  |  |
| P3E07S3 |  | E07 UPS/DC-System - Goods arriv. at Site CA31 | milestone | 0d | 2011-05-25 A | 2011-05-25 A | P3E07N FF, P3E07G | 100% |  |  | TB26 - 2 - Manuf and Delivy |  |  |  | P3E07S3 | P3E07S3 | 860 | E07 | 31 | 2EB5610 | 200 | 200 | 400 | P | OWN | 0 | P | E | EE24 | 3130 | IT | LND |  |  |  |
|  | J | **J Instrumentation** |  |  | 2011-07-15 | 2011-08-16 |  |  |  |  |  |  |  |  |  |  |  |  |  |  |  |  |  |  |  |  |  |  |  |  |  |  |  |  |  |
| P3J06S3 |  | J06 DCS / SIS - Goods arr.at Site CA31 | milestone | 0d | 2011-07-15 A | 2011-07-15 A | P3J06N FF | 100% |  |  | TB26 - 2 - Manuf and Delivy |  |  |  | P3J06S3 | P3J06S3 | 860 | J06 | 31 | 2JD9220 | 200 | 200 | 400 | P | LND | 0 | P | J | PJ29 | 3130 | INS | LND |  |  |  |
| P3J06CS2 |  | J06B Interface/Special Dev. Cabinets (E+I)-Goods arr.at Site CA31 | milestone | 0d | 2011-08-16 A | 2011-08-16 A | HPJJ06B FF, P3J06BN FF, P3J06BG | 100% |  |  | TB26 - 2 - Manuf and Delivy |  |  |  | P3J06CS2 | P3J06CS2 | 860 | J06B | 31 | 2JD9640 | 200 | 200 | 400 | P | OWN | 0 | P | J | PJ29 | 3130 | IT | LND |  |  |  |
|  | 3140 | **3140 Warehouse - CA31** |  |  | 2010-11-20 | 2011-11-24 |  |  |  |  |  |  |  |  |  |  |  |  |  |  |  |  |  |  |  |  |  |  |  |  |  |  |  |  |  |
|  | N | **N Structural Steel** |  |  | 2010-11-20 | 2011-05-18 |  |  |  |  |  |  |  |  |  |  |  |  |  |  |  |  |  |  |  |  |  |  |  |  |  |  |  |  |  |
| P3N02#E |  | CA31 Staircase SK3105 - Vendor Procurement |  | 35d | 2010-11-20 A | 2010-12-24 A | EN27311510 | 100% |  |  | TB26 - 2 - Manuf and Delivy |  |  |  | P3N02#E | P3N02#E | 860 | N02# | 31 | N02# | 200 | 200 | 400 | P | Chel | 0 | P | N | PN25 | 3140 | SS | LND |  | DEL |  |
| P3N02ЦE |  | CA31 Warehouse SK3102 - Vendor Procurement |  | 30d | 2011-01-22 A | 2011-02-20 A | EN27314010 | 100% |  |  | TB26 - 2 - Manuf and Delivy |  |  |  | P3N02ЦE | P3N02ЦE | 860 | N02Ц | 31 | N02Ц | 200 | 200 | 400 | P | Chel | 0 | P | N | PN25 | 3140 | SS | LND |  | DEL |  |
| P3N02ЦL |  | CA31 Warehouse SK3102 - Vendor Fabrication |  | 45d | 2011-03-19 A | 2011-05-03 A | EN283140 SS+20d, P3N02ЦE SS+20d | 100% |  |  | TB26 - 2 - Manuf and Delivy |  |  |  | P3N02ЦL | P3N02ЦL | 860 | N02Ц | 31 | N02Ц | 200 | 200 | 400 | P | Chel | 0 | P | N | PN26 | 3140 | SS | LND |  | DEL |  |
| PN663140 |  | CA31 Warehouse SK3102 - Fabrication Gratings |  | 45d | 2011-03-19 A | 2011-05-03 A | EN643140 FF, P3N02ЦL SS, EN683140 | 100% |  |  | TB26 - 2 - Manuf and Delivy |  |  |  | PN663140 | PN663140 | 860 | N02Ц | 31 | N02Ц | 200 | 200 |  | C | OWN |  | P | N | PN66 | 3140 | SS | LND |  |  |  |
| P3N02ЦP |  | CA31 Warehouse SK3102 - Transport to Site |  | 15d | 2011-05-04 A | 2011-05-18 A | P3N02ЦL | 100% |  |  | TB26 - 2 - Manuf and Delivy | Piperacks, Main Structures (Delivery) [242 t]; Ladders & Platforms (Delivery) [75 t] |  |  | P3N02ЦP | P3N02ЦP | 860 | N02Ц | 31 | N02Ц | 200 | 200 | 400 | P | Chel | 0 | P | N | PN28 | 3140 | SS | LND |  |  | 0,00 |
| PN683140 |  | CA31 Warehouse SK3102 - Transport Gratings to Site |  | 15d | 2011-05-04 A | 2011-05-18 A | PN663140 | 100% |  |  | TB26 - 2 - Manuf and Delivy |  |  |  | PN683140 | PN683140 | 860 | N02Ц | 31 | N02Ц | 200 | 200 |  | C | OWN |  | P | N | PN68 | 3140 | SS | LND |  |  |  |
| P3N02ЦN |  | CA31 Warehouse SK3102 - Goods arrived at Site | milestone | 0d | 2011-05-13 A | 2011-05-13 A | P3N02ЦP SF+10d | 100% |  |  | TB26 - 2 - Manuf and Delivy |  |  |  | P3N02ЦN | P3N02ЦN | 860 | N02Ц | 31 | N02Ц | 200 | 200 | 400 | P | Chel | L2 | P | N | PN29 | 3140 | SS | LND |  |  |  |
| PN693140 |  | CA31 Warehouse SK3102 - Gratings arrived at Site | milestone | 0d | 2011-05-18 A | 2011-05-18 A | PN683140 FF | 100% |  |  | TB26 - 2 - Manuf and Delivy |  |  |  | PN693140 | PN693140 | 860 | N02Ц | 31 | N02Ц | 200 | 200 |  | C | OWN |  | P | N | PN69 | 3140 | S | LND |  |  |  |

Notes:
- P3H01SR: UDF_Actictity Name (Russia): H01 Оборудование ОВКВ - Прибытие 1-й партии товара на площадку, CA31 Нагнетатели
- P3U10S3: Expenses: 900A 311856
- P3N02ДN: UDF_Actictity Name (Russia): CA31 Офисное здание SK3103 - Прибытие товара на площадку
- P3H01SS: UDF_Actictity Name (Russia): H01 Оборудование ОВКВ - Прибытие 1-й партии товара на площадку, CA31 Офисы
- P3N02ЦN: UDF_Actictity Name (Russia): CA31 Здание подготовки и отгрузки продукта SK3102 - Прибытие товара на площадку

| ID | WBS | Activity | Type | Duration | Start | Finish | Predecessors | Complete | Total float | Free float | Calendar | Resources | Cost | Actual cost | UDF_SAVE ACTID | UDF_SAVE ACT ID | Department | Type of Work | Constr. Area | Inquiry/Order No | PMT-Area | PMT-Schedule Org | PMT-Discipline | PMT-Phase | PMT-Respons. | Zeigen/n. Zeigen | WBS Phase | WBS Discipline | WBS Type of Work | WBS Objects | IMS | UPT | Pro Unit/DocCode | PMT-Doc. Type | TB26 Ressource Budget |
| --- | --- | --- | --- | --- | --- | --- | --- | --- | --- | --- | --- | --- | --- | --- | --- | --- | --- | --- | --- | --- | --- | --- | --- | --- | --- | --- | --- | --- | --- | --- | --- | --- | --- | --- | --- |
|  | H | **H HVAC** |  |  | 2011-11-24 | 2011-11-24 |  |  |  |  |  |  |  |  |  |  |  |  |  |  |  |  |  |  |  |  |  |  |  |  |  |  |  |  |  |
| P3H01ST |  | H01 HVAC Eqt. - 1stGoods arr. at Site CA31 WH | milestone | 0d | 2011-11-24 | 2011-11-24 | P3H01P SF+240d |  | 92d | 28d | TB26 - 2 - Manuf and Delivy |  |  |  | P3H01ST | P3H01ST | 860 | H01 | 31 | H01 | 000 | 200 | 400 | P | SC | L2 | P | H | PH19 | 3140 | hva_as | LND |  |  |  |
|  | U | **U Package Units** |  |  | 2011-09-24 | 2011-09-24 |  |  |  |  |  |  |  |  |  |  |  |  |  |  |  |  |  |  |  |  |  |  |  |  |  |  |  |  |  |
| P3U07S |  | PU07 Packaging Syst.- Goods arrived at Site CA31 | milestone | 0d | 2011-09-24 | 2011-09-24 | IMS-P-000050 (other project) FF, P3U07N FF, P3U07G, HPU07 FF |  | 45d | 111d | TB26 - 2 - Manuf and Delivy |  | 192,475 |  | P3U07S | P3U07S | 860 | PU07 | 31 | 2DC9020 | 200 | 200 | 400 | P | OWN | C2 | P | U | PU39 | 3140 | S | LND | DC |  |  |
|  | 41 | **41 CA41 - Control Building** |  |  | 2010-12-11 | 2010-12-11 |  |  |  |  |  |  |  |  |  |  |  |  |  |  |  |  |  |  |  |  |  |  |  |  |  |  |  |  |  |
|  | 4100 | **4100 Generals - CA41** |  |  | 2010-12-11 | 2010-12-11 |  |  |  |  |  |  |  |  |  |  |  |  |  |  |  |  |  |  |  |  |  |  |  |  |  |  |  |  |  |
|  | E | **E Electrical** |  |  | 2010-12-11 | 2010-12-11 |  |  |  |  |  |  |  |  |  |  |  |  |  |  |  |  |  |  |  |  |  |  |  |  |  |  |  |  |  |
| P3E01AS4 |  | E01A MV-SWG/MCC - Goods arr. at Site CA41 | milestone | 0d | 2010-12-11 A | 2010-12-11 A | HPEE01A FF, P3E01AN FF, P3E01AG | 100% |  |  | TB26 - 2 - Manuf and Delivy |  | 116,590 | 116,590 | P3E01AS4 | P3E01AS4 | 860 | E01A | 41 | 2EB5640 | 200 | 200 | 400 | P | OWN | 0 | P | E | EE20 | 4100 | ELE | LND |  |  |  |
|  | 51 | **51 CA51 - Piperack (btw. CA11-15/17/19/52/53/54)** |  |  | 2010-09-04 | 2011-02-20 |  |  |  |  |  |  |  |  |  |  |  |  |  |  |  |  |  |  |  |  |  |  |  |  |  |  |  |  |  |
|  | 5101 | **5101 Pipe Rack 1 - Part 1 - CA51** |  |  | 2010-09-11 | 2011-02-20 |  |  |  |  |  |  |  |  |  |  |  |  |  |  |  |  |  |  |  |  |  |  |  |  |  |  |  |  |  |
|  | N | **N Structural Steel** |  |  | 2010-09-11 | 2011-02-20 |  |  |  |  |  |  |  |  |  |  |  |  |  |  |  |  |  |  |  |  |  |  |  |  |  |  |  |  |  |
| P3N01AE |  | CA51 SR5101 - Vendor Procurement |  | 40d | 2010-09-11 A | 2010-10-20 A | EN27510110 | 100% |  |  | TB26 - 2 - Manuf and Delivy |  |  |  | P3N01AE | P3N01AE | 860 | N01A | 51 | N01A | 200 | 200 | 400 | P | Chel | 0 | P | N | PN25 | 5101 | SS | LND |  | DEL |  |
| P3N01AL |  | CA51 SR5101 - Vendor Fabrication |  | 78d | 2010-11-22 A | 2011-02-10 A | P3N01AE SS+20d, EN285101 SS+25d | 100% |  |  | TB26 - 2 - Manuf and Delivy |  |  |  | P3N01AL | P3N01AL | 860 | N01A | 51 | N01A | 200 | 200 | 400 | P | Chel | 0 | P | N | PN26 | 5101 | SS | LND |  | DEL |  |
| P3N01AP |  | CA51 SR5101 - Transport to Site |  | 10d | 2011-02-11 A | 2011-02-20 A | P3N01AL | 100% |  |  | TB26 - 2 - Manuf and Delivy | Piperacks, Main Structures (Delivery) [95 t]; Ladders & Platforms (Delivery) [8 t] |  |  | P3N01AP | P3N01AP | 860 | N01A | 51 | N01A | 200 | 200 | 400 | P | Chel | 0 | P | N | PN28 | 5101 | SS | LND |  |  | 0,00 |
| P3N01AN |  | CA51 SR5101 - Goods arrived at Site | milestone | 0d | 2011-02-20 A | 2011-02-20 A | P3N01AP FF | 100% |  |  | TB26 - 2 - Manuf and Delivy |  |  |  | P3N01AN | P3N01AN | 860 | N01A | 51 | N01A | 200 | 200 | 400 | P | Chel | L2 | P | N | PN29 | 5101 | M | LND |  |  |  |
|  | 5102 | **5102 Pipe Rack 1 - Part 2 - CA51** |  |  | 2010-09-04 | 2011-02-20 |  |  |  |  |  |  |  |  |  |  |  |  |  |  |  |  |  |  |  |  |  |  |  |  |  |  |  |  |  |
|  | N | **N Structural Steel** |  |  | 2010-09-04 | 2011-02-20 |  |  |  |  |  |  |  |  |  |  |  |  |  |  |  |  |  |  |  |  |  |  |  |  |  |  |  |  |  |
| P3N01BE |  | CA51 SR5102 - Vendor Procurement |  | 40d | 2010-09-04 A | 2010-10-13 A | EN27510210 | 100% |  |  | TB26 - 2 - Manuf and Delivy |  |  |  | P3N01BE | P3N01BE | 860 | N01B | 51 | N01B | 200 | 200 | 400 | P | Chel | 0 | P | N | PN25 | 5102 | SS | LND |  | DEL |  |
| P3N01BL |  | CA51 SR5102 - Vendor Fabrication |  | 91d | 2010-11-09 A | 2011-02-10 A | EN285102 SS+22d, P3N01BE SS+20d | 100% |  |  | TB26 - 2 - Manuf and Delivy |  |  |  | P3N01BL | P3N01BL | 860 | N01B | 51 | N01B | 200 | 200 | 400 | P | Chel | 0 | P | N | PN26 | 5102 | SS | LND |  | DEL |  |
| P3N01BP |  | CA51 SR5102 - Transport to Site |  | 10d | 2011-02-11 A | 2011-02-20 A | P3N01BL | 100% |  |  | TB26 - 2 - Manuf and Delivy | Piperacks, Main Structures (Delivery) [230 t]; Ladders & Platforms (Delivery) [6 t] |  |  | P3N01BP | P3N01BP | 860 | N01B | 51 | N01B | 200 | 200 | 400 | P | Chel | 0 | P | N | PN28 | 5102 | SS | LND |  |  | 0,00 |
| P3N01BN |  | CA51 SR5102 - Goods arrived at Site | milestone | 0d | 2011-02-20 A | 2011-02-20 A | P3N01BP FF | 100% |  |  | TB26 - 2 - Manuf and Delivy |  |  |  | P3N01BN | P3N01BN | 860 | N01B | 51 | N01B | 200 | 200 | 400 | P | Chel | L2 | P | N | PN29 | 5102 | M | LND |  |  |  |
|  | 5103 | **5103 Pipe Rack 1 - Part 3 - CA51** |  |  | 2010-09-04 | 2011-02-10 |  |  |  |  |  |  |  |  |  |  |  |  |  |  |  |  |  |  |  |  |  |  |  |  |  |  |  |  |  |
|  | N | **N Structural Steel** |  |  | 2010-09-04 | 2011-02-10 |  |  |  |  |  |  |  |  |  |  |  |  |  |  |  |  |  |  |  |  |  |  |  |  |  |  |  |  |  |
| P3N01CE |  | CA51 SR5103 - Vendor Procurement |  | 40d | 2010-09-04 A | 2010-10-13 A | EN27510310 | 100% |  |  | TB26 - 2 - Manuf and Delivy |  |  |  | P3N01CE | P3N01CE | 860 | N01C | 51 | N01C | 200 | 200 | 400 | P | Chel | 0 | P | N | PN25 | 5103 | SS | LND |  | DEL |  |
| P3N01CL |  | CA51 SR5103 - Vendor Fabrication |  | 81d | 2010-11-09 A | 2011-01-31 A | EN285103 SS+22d, P3N01CE SS+20d | 100% |  |  | TB26 - 2 - Manuf and Delivy |  |  |  | P3N01CL | P3N01CL | 860 | N01C | 51 | N01C | 200 | 200 | 400 | P | Chel | 0 | P | N | PN26 | 5103 | SS | LND |  | DEL |  |
| P3N01CP |  | CA51 SR5103 - Transport to Site |  | 10d | 2011-02-01 A | 2011-02-10 A | P3N01CL | 100% |  |  | TB26 - 2 - Manuf and Delivy | Piperacks, Main Structures (Delivery) [170 t]; Ladders & Platforms (Delivery) [2 t] |  |  | P3N01CP | P3N01CP | 860 | N01C | 51 | N01C | 200 | 200 | 400 | P | Chel | 0 | P | N | PN28 | 5103 | SS | LND |  |  | 0,00 |
| P3N01CN |  | CA51 SR5103 - Goods arrived at Site | milestone | 0d | 2011-02-10 A | 2011-02-10 A | P3N01CP FF | 100% |  |  | TB26 - 2 - Manuf and Delivy |  |  |  | P3N01CN | P3N01CN | 860 | N01C | 51 | N01C | 200 | 200 | 400 | P | Chel | L2 | P | N | PN29 | 5103 | M | LND |  |  |  |

Notes:
- P3H01ST: UDF_Actictity Name (Russia): H01 Оборудование ОВКВ - Прибытие 1-й партии товара на площадку, CA31 Склад
- P3U07S: Expenses: 900A 192475
- P3E01AS4: Expenses: 900A 116590
- P3N01AN: UDF_Actictity Name (Russia): CA51 SR5101 (N01A) - Прибытие товара на площадку
- P3N01BN: UDF_Actictity Name (Russia): CA51 SR5102 (N01B) - Прибытие товара на площадку
- P3N01CN: UDF_Actictity Name (Russia): CA51 SR5103 (N01C) - Прибытие товара на площадку

| ID | WBS | Activity | Type | Duration | Start | Finish | Predecessors | Complete | Planned start | Planned finish | Calendar | Resources | UDF_SAVE ACTID | UDF_SAVE ACT ID | Department | Type of Work | Constr. Area | Inquiry/Order No | PMT-Area | PMT-Schedule Org | PMT-Discipline | PMT-Phase | PMT-Doc. Type | PMT-Respons. | Zeigen/n. Zeigen | WBS Phase | WBS Discipline | WBS Type of Work | WBS Objects | IMS | UPT | TB26 Ressource Budget | UDF_Actictity Name (Russia) |
| --- | --- | --- | --- | --- | --- | --- | --- | --- | --- | --- | --- | --- | --- | --- | --- | --- | --- | --- | --- | --- | --- | --- | --- | --- | --- | --- | --- | --- | --- | --- | --- | --- | --- |
|  | 5104 | **5104 Pipe Rack 1 - Part 4 - CA51** |  |  | 2010-09-04 | 2011-02-10 |  |  |  |  |  |  |  |  |  |  |  |  |  |  |  |  |  |  |  |  |  |  |  |  |  |  |  |
|  | N | **N Structural Steel** |  |  | 2010-09-04 | 2011-02-10 |  |  |  |  |  |  |  |  |  |  |  |  |  |  |  |  |  |  |  |  |  |  |  |  |  |  |  |
| P3N01DE |  | CA51 SR5104 - Vendor Procurement |  | 40d | 2010-09-04 A | 2010-10-13 A | EN27510410 | 100% |  |  | TB26 - 2 - Manuf and Delivy |  | P3N01DE | P3N01DE | 860 | N01D | 51 | N01D | 200 | 200 | 400 | P | DEL | Chel | 0 | P | N | PN25 | 5104 | SS | LND |  |  |
| P3N01DL |  | CA51 SR5104 - Vendor Fabrication |  | 81d | 2010-11-09 A | 2011-01-31 A | P3N01DE SS+20d, EN285104 SS+22d | 100% |  |  | TB26 - 2 - Manuf and Delivy |  | P3N01DL | P3N01DL | 860 | N01D | 51 | N01D | 200 | 200 | 400 | P | DEL | Chel | 0 | P | N | PN26 | 5104 | SS | LND |  |  |
| P3N01DP |  | CA51 SR5104 - Transport to Site |  | 10d | 2011-02-01 A | 2011-02-10 A | P3N01DL | 100% |  |  | TB26 - 2 - Manuf and Delivy | Piperacks, Main Structures (Delivery) [110 t]; Ladders & Platforms (Delivery) [5 t] | P3N01DP | P3N01DP | 860 | N01D | 51 | N01D | 200 | 200 | 400 | P |  | Chel | 0 | P | N | PN28 | 5104 | SS | LND | 0,00 |  |
| P3N01DN |  | CA51 SR5104 - Goods arrived at Site | milestone | 0d | 2011-02-10 A | 2011-02-10 A | P3N01DP FF, P3N100 FF | 100% |  |  | TB26 - 2 - Manuf and Delivy |  | P3N01DN | P3N01DN | 860 | N01D | 51 | N01D | 200 | 200 | 400 | P |  | Chel | L2 | P | N | PN29 | 5104 | M | LND |  | CA51 SR5104 (N01D) - Прибытие товара на площадку |
|  | 52 | **52 CA52 - Piperack (between CA11/51)** |  |  | 2011-01-08 | 2011-04-09 |  |  |  |  |  |  |  |  |  |  |  |  |  |  |  |  |  |  |  |  |  |  |  |  |  |  |  |
|  | 5201 | **5201 Pipe Rack 2 - CA52** |  |  | 2011-01-08 | 2011-04-09 |  |  |  |  |  |  |  |  |  |  |  |  |  |  |  |  |  |  |  |  |  |  |  |  |  |  |  |
|  | N | **N Structural Steel** |  |  | 2011-01-08 | 2011-04-09 |  |  |  |  |  |  |  |  |  |  |  |  |  |  |  |  |  |  |  |  |  |  |  |  |  |  |  |
| P3N01EE |  | CA52 SR5201- Vendor Procurement |  | 49d | 2011-01-08 A | 2011-02-25 A | EN27520110 | 100% |  |  | TB26 - 2 - Manuf and Delivy |  | P3N01EE | P3N01EE | 860 | N01E | 52 | N01E | 200 | 200 | 400 | P | DEL | Chel | 0 | P | N | PN25 | 5201 | SS | LND |  |  |
| P3N01EL |  | CA52 SR5201 - Vendor Fabrication |  | 59d | 2011-01-31 A | 2011-03-31 A | P3N01EE SS+17d, EN285201 SS+18d | 100% | 2011-01-31 | 2011-03-30 | TB26 - 2 - Manuf and Delivy |  | P3N01EL | P3N01EL | 860 | N01E | 52 | N01E | 200 | 200 | 400 | P | DEL | Chel | 0 | P | N | PN26 | 5201 | SS | LND |  |  |
| P3N01EP |  | CA52 SR5201 - Transport to Site |  | 10d | 2011-03-31 A | 2011-04-09 A | P3N01EL | 100% |  |  | TB26 - 2 - Manuf and Delivy | Piperacks, Main Structures (Delivery) [130 t]; Ladders & Platforms (Delivery) [7 t] | P3N01EP | P3N01EP | 860 | N01E | 52 | N01E | 200 | 200 | 400 | P |  | Chel | 0 | P | N | PN28 | 5201 | SS | LND | 0,00 |  |
| P3N01EN |  | CA52 SR5201 - Goods arrived at Site | milestone | 0d | 2011-04-09 A | 2011-04-09 A | P3N01EP | 100% |  |  | TB26 - 2 - Manuf and Delivy |  | P3N01EN | P3N01EN | 860 | N01E | 52 | N01E | 200 | 200 | 400 | P |  | Chel | L2 | P | N | PN29 | 5201 | M | LND |  | CA52 SR5201 (N01E) - Прибытие товара на площадку |
|  | 53 | **53 CA53 - Piperack (between CA14/51)** |  |  | 2011-04-20 | 2011-08-19 |  |  |  |  |  |  |  |  |  |  |  |  |  |  |  |  |  |  |  |  |  |  |  |  |  |  |  |
|  | 5301 | **5301 Pipe Rack 3 - CA53** |  |  | 2011-04-20 | 2011-08-19 |  |  |  |  |  |  |  |  |  |  |  |  |  |  |  |  |  |  |  |  |  |  |  |  |  |  |  |
|  | N | **N Structural Steel** |  |  | 2011-04-20 | 2011-08-19 |  |  |  |  |  |  |  |  |  |  |  |  |  |  |  |  |  |  |  |  |  |  |  |  |  |  |  |
| P3N53IE |  | CA53 PR5301 - Vendor Procurement |  | 35d | 2011-04-20 A | 2011-05-25 A | EN27530110 FF+18d | 100% |  |  | TB26 - 2 - Manuf and Delivy |  | P3N53IE | P3N53IE | 860 | N01F | 53 | N01F | 200 | 200 | 400 | P | DEL | Chel | FL | P | N | PN25 | 5301 | SS | LND |  |  |
| P3N53IL |  | CA53 PR5301 - Vendor Fabrication |  | 72d | 2011-05-30 A | 2011-08-09 A | P3N53IE SS+15d, EN285301 SS+15d | 100% |  |  | TB26 - 2 - Manuf and Delivy |  | P3N53IL | P3N53IL | 860 | N01F | 53 | N01F | 200 | 200 | 400 | P | DEL | Chel | FL | P | N | PN26 | 5301 | SS | LND |  |  |
| P3N53IP |  | CA53 PR5301 - Transport to Site |  | 10d | 2011-08-10 A | 2011-08-19 A | P3N53IL | 100% |  |  | TB26 - 2 - Manuf and Delivy | Piperacks, Main Structures (Delivery); Ladders & Platforms (Delivery) | P3N53IP | P3N53IP | 860 | N01F | 53 | N01F | 200 | 200 | 400 | P |  | Chel | FL | P | N | PN28 | 5301 | SS | LND | 0,00 |  |
| P3N53IN |  | CA53 PR5301 - Goods arrived at Site | milestone | 0d | 2011-08-19 A | 2011-08-19 A | P3N53IP FF | 100% |  |  | TB26 - 2 - Manuf and Delivy |  | P3N53IN | P3N53IN | 860 | N01F | 53 | N01F | 200 | 200 | 400 | P |  | Chel | FL | P | N | PN29 | 5301 | M | LND |  |  |
|  | 54 | **54 CA54 - Piperack (between CA15/16/51/55)** |  |  | 2010-10-08 | 2011-03-07 |  |  |  |  |  |  |  |  |  |  |  |  |  |  |  |  |  |  |  |  |  |  |  |  |  |  |  |
|  | 5401 | **5401 Pipe Rack 4 - Part 1 - CA54** |  |  | 2010-10-20 | 2011-02-20 |  |  |  |  |  |  |  |  |  |  |  |  |  |  |  |  |  |  |  |  |  |  |  |  |  |  |  |
|  | N | **N Structural Steel** |  |  | 2010-10-20 | 2011-02-20 |  |  |  |  |  |  |  |  |  |  |  |  |  |  |  |  |  |  |  |  |  |  |  |  |  |  |  |
| P3N01GE |  | CA54 SR5401 - Vendor Procurement |  | 47d | 2010-10-20 A | 2010-12-05 A | EN27540110 | 100% |  |  | TB26 - 2 - Manuf and Delivy |  | P3N01GE | P3N01GE | 860 | N01G | 54 | N01G | 200 | 200 | 400 | P | DEL | Chel | 0 | P | N | PN25 | 5401 | SS | LND |  |  |
| P3N01GL |  | CA54 SR5401 - Vendor Fabrication |  | 61d | 2010-12-09 A | 2011-02-10 A | P3N01GE SS+20d, EN285401 SS+35d | 100% |  |  | TB26 - 2 - Manuf and Delivy |  | P3N01GL | P3N01GL | 860 | N01G | 54 | N01G | 200 | 200 | 400 | P | DEL | Chel | 0 | P | N | PN26 | 5401 | SS | LND |  |  |
| P3N01GP |  | CA54 SR5401 - Transport to Site |  | 10d | 2011-02-11 A | 2011-02-20 A | P3N01GL | 100% |  |  | TB26 - 2 - Manuf and Delivy | Piperacks, Main Structures (Delivery) [155 t]; Ladders & Platforms (Delivery) [1 t] | P3N01GP | P3N01GP | 860 | N01G | 54 | N01G | 200 | 200 | 400 | P |  | Chel | 0 | P | N | PN28 | 5401 | SS | LND | 0,00 |  |
| P3N01GN |  | CA54 SR5401 - Goods arrived at Site | milestone | 0d | 2011-02-20 A | 2011-02-20 A | P3N01GP FF, P3N100 FF | 100% |  |  | TB26 - 2 - Manuf and Delivy |  | P3N01GN | P3N01GN | 860 | N01G | 54 | N01G | 200 | 200 | 400 | P |  | Chel | L2 | P | N | PN29 | 5401 | M | LND |  | CA54 SR5401 (N01G) - Прибытие товара на площадку |

| ID | WBS | Activity | Type | Duration | Start | Finish | Predecessors | Complete | Calendar | Resources | UDF_SAVE ACTID | UDF_SAVE ACT ID | Department | Type of Work | Constr. Area | Inquiry/Order No | PMT-Area | PMT-Schedule Org | PMT-Discipline | PMT-Phase | PMT-Doc. Type | PMT-Respons. | Zeigen/n. Zeigen | WBS Phase | WBS Discipline | WBS Type of Work | WBS Objects | IMS | UPT | TB26 Ressource Budget | UDF_Actictity Name (Russia) |
| --- | --- | --- | --- | --- | --- | --- | --- | --- | --- | --- | --- | --- | --- | --- | --- | --- | --- | --- | --- | --- | --- | --- | --- | --- | --- | --- | --- | --- | --- | --- | --- |
|  | 5402 | **5402 Pipe Rack 4 - Part 2 - CA54** |  |  | 2010-10-08 | 2011-03-07 |  |  |  |  |  |  |  |  |  |  |  |  |  |  |  |  |  |  |  |  |  |  |  |  |  |
|  | N | **N Structural Steel** |  |  | 2010-10-08 | 2011-03-07 |  |  |  |  |  |  |  |  |  |  |  |  |  |  |  |  |  |  |  |  |  |  |  |  |  |
| P3N01HE |  | CA54 SR5402 - Vendor Procurement |  | 64d | 2010-10-08 A | 2010-12-10 A | EN27540210 | 100% | TB26 - 2 - Manuf and Delivy |  | P3N01HE | P3N01HE | 860 | N01H | 54 | N01H | 200 | 200 | 400 | P | DEL | Chel | 0 | P | N | PN25 | 5402 | SS | LND |  |  |
| P3N01HL |  | CA54 SR5402 - Vendor Fabrication |  | 74d | 2010-12-11 A | 2011-02-25 A | P3N01HE SS+20d, EN285402 SS+45d | 100% | TB26 - 2 - Manuf and Delivy |  | P3N01HL | P3N01HL | 860 | N01H | 54 | N01H | 200 | 200 | 400 | P | DEL | Chel | 0 | P | N | PN26 | 5402 | SS | LND |  |  |
| P3N01HP |  | CA54 SR5402 - Transport to Site |  | 10d | 2011-02-26 A | 2011-03-07 A | P3N01HL | 100% | TB26 - 2 - Manuf and Delivy | Piperacks, Main Structures (Delivery) [35 t]; Ladders & Platforms (Delivery) [3 t] | P3N01HP | P3N01HP | 860 | N01H | 54 | N01H | 200 | 200 | 400 | P |  | Chel | 0 | P | N | PN28 | 5402 | SS | LND | 0,00 |  |
| P3N01HN |  | CA54 SR5402 - Goods arrived at Site | milestone | 0d | 2011-03-07 A | 2011-03-07 A | P3N01HP FF | 100% | TB26 - 2 - Manuf and Delivy |  | P3N01HN | P3N01HN | 860 | N01H | 54 | N01H | 200 | 200 | 400 | P |  | Chel | L2 | P | N | PN29 | 5402 | M | LND |  | CA54 SR5402 (N01H) - Прибытие товара на площадку |
|  | 55 | **55 CA55 - Piperack (between CA16/17/56)** |  |  | 2008-03-03 | 2011-02-05 |  |  |  |  |  |  |  |  |  |  |  |  |  |  |  |  |  |  |  |  |  |  |  |  |  |
|  | 5501 | **5501 Pipe Rack 5 - Part 1 - CA55** |  |  | 2010-09-29 | 2011-02-05 |  |  |  |  |  |  |  |  |  |  |  |  |  |  |  |  |  |  |  |  |  |  |  |  |  |
|  | N | **N Structural Steel** |  |  | 2010-09-29 | 2011-02-05 |  |  |  |  |  |  |  |  |  |  |  |  |  |  |  |  |  |  |  |  |  |  |  |  |  |
| P3N01IE |  | CA55 SR5501 - Vendor Procurement |  | 50d | 2010-09-29 A | 2010-11-17 A | EN27550110 | 100% | TB26 - 2 - Manuf and Delivy |  | P3N01IE | P3N01IE | 860 | N01I | 55 | N01I | 200 | 200 | 400 | P | DEL | Chel | 0 | P | N | PN25 | 5501 | SS | LND |  |  |
| P3N01IL |  | CA55 SR5501 - Vendor Fabrication |  | 60d | 2010-11-25 A | 2011-01-26 A | EN285501 SS+40d, P3N01IE SS+25d | 100% | TB26 - 2 - Manuf and Delivy |  | P3N01IL | P3N01IL | 860 | N01I | 55 | N01I | 200 | 200 | 400 | P | DEL | Chel | 0 | P | N | PN26 | 5501 | SS | LND |  |  |
| P3N01IP |  | CA55 SR5501 - Transport to Site |  | 10d | 2011-01-27 A | 2011-02-05 A | P3N01IL | 100% | TB26 - 2 - Manuf and Delivy | Piperacks, Main Structures (Delivery) [35 t]; Ladders & Platforms (Delivery) [1 t] | P3N01IP | P3N01IP | 860 | N01I | 55 | N01I | 200 | 200 | 400 | P |  | Chel | 0 | P | N | PN28 | 5501 | SS | LND | 0,00 |  |
| P3N01IN |  | CA55 SR5501 - Goods arrived at Site | milestone | 0d | 2011-02-05 A | 2011-02-05 A | P3N01IP FF | 100% | TB26 - 2 - Manuf and Delivy |  | P3N01IN | P3N01IN | 860 | N01I | 55 | N01I | 200 | 200 | 400 | P |  | Chel | L2 | P | N | PN29 | 5501 | M | LND |  | CA55 SR5501 (N01I) - Прибытие товара на площадку |
|  | 5502 | **5502 Pipe Rack 5 - Part 2 - CA55** |  |  | 2010-09-29 | 2011-02-05 |  |  |  |  |  |  |  |  |  |  |  |  |  |  |  |  |  |  |  |  |  |  |  |  |  |
|  | N | **N Structural Steel** |  |  | 2010-09-29 | 2011-02-05 |  |  |  |  |  |  |  |  |  |  |  |  |  |  |  |  |  |  |  |  |  |  |  |  |  |
| P3N01LE |  | CA55 SR5502 - Vendor Procurement |  | 50d | 2010-09-29 A | 2010-11-17 A | EN27550210 | 100% | TB26 - 2 - Manuf and Delivy |  | P3N01LE | P3N01LE | 860 | N01L | 55 | N01L | 200 | 200 | 400 | P | DEL | Chel | 0 | P | N | PN25 | 5502 | SS | LND |  |  |
| P3N01LL |  | CA55 SR5502 - Vendor Fabrication |  | 60d | 2010-11-25 A | 2011-01-26 A | P3N01LE SS+25d, EN285502 SS+40d | 100% | TB26 - 2 - Manuf and Delivy |  | P3N01LL | P3N01LL | 860 | N01L | 55 | N01L | 200 | 200 | 400 | P | DEL | Chel | 0 | P | N | PN26 | 5502 | SS | LND |  |  |
| P3N01LP |  | CA55 SR5502 - Transport to Site |  | 10d | 2011-01-27 A | 2011-02-05 A | P3N01LL | 100% | TB26 - 2 - Manuf and Delivy | Ladders & Platforms (Delivery) [1 t]; Piperacks, Main Structures (Delivery) [80 t] | P3N01LP | P3N01LP | 860 | N01L | 55 | N01L | 200 | 200 | 400 | P |  | Chel | 0 | P | N | PN28 | 5502 | SS | LND | 0,00 |  |
| P3N01LN |  | CA55 SR5502 - Goods arrived at Site | milestone | 0d | 2011-02-05 A | 2011-02-05 A | P3N01LP FF | 100% | TB26 - 2 - Manuf and Delivy |  | P3N01LN | P3N01LN | 860 | N01L | 55 | N01L | 200 | 200 | 400 | P |  | Chel | L2 | P | N | PN29 | 5502 | M | LND |  | CA55 SR5502 (N01L) - Прибытие товара на площадку |
|  | 5503 | **5503 Pipe Rack 5 - Part 3 - CA55** |  |  | 2008-03-03 | 2011-02-05 |  |  |  |  |  |  |  |  |  |  |  |  |  |  |  |  |  |  |  |  |  |  |  |  |  |
|  | N | **N Structural Steel** |  |  | 2008-03-03 | 2011-02-05 |  |  |  |  |  |  |  |  |  |  |  |  |  |  |  |  |  |  |  |  |  |  |  |  |  |
| EN155503 |  | CA55 SR5503 - CAD Model/Concepts StrSteel |  | 126d | 2008-03-03 A | 2008-08-29 A | EN155501 FF | 100% |  |  | EN155503 | EN155503 | 87B | N01M | 55 | N01M | 200 | 200 | 055 | E |  | LND | 0 | E | N | EN15 | 5503 | de | LND |  |  |
| EN21550305 |  | CA55 SR5503 - GA-Drwgs + Fdtn Loads |  | 15d | 2009-03-23 A | 2009-04-14 A | AD2230 FS+60d, ER165503, EE46550305, EN155503 FF, EJ46550305 | 100% |  |  | EN21550305 | EN21550305 | 87B | N01M | 55 | N01M | 200 |  |  |  |  | LND |  | E | N | EN21 | 5503 | de | LND |  |  |
| EN24550305 |  | CA55 SR5503 - Static Calc for Fdtn Loads |  | 25d | 2009-11-16 A | 2009-12-21 A | EN21550305 | 100% |  |  | EN24550305 | EN24550305 | 87B | N01M | 55 | N01M | 200 |  |  |  |  | LND |  | E | N | EN24 | 5503 | de | LND |  |  |
| EN255503 |  | CA55 SR5503 - Loads for Civil | milestone | 0d | 2009-12-21 A | 2009-12-21 A | EN24550305 FF, HEN25 FF | 100% |  |  | EN255503 | EN255503 | 87B | N01M | 55 | N01M | 200 | 200 | 055 | E |  | LND | 0 | E | N | EN25 | 5503 | de | LND |  |  |
| EN21550310 |  | CA55 SR5503 - GA-Drwgs + Final Loads |  | 60d | 2009-12-22 A | 2010-03-19 A | EN24550305, EN21550305 FS+10d, EE46550308, EJ46550308, ER425503 | 100% |  | TKB-S [192 h] | EN21550310 | EN21550310 | 87B | N01M | 55 | N01M | 200 |  |  |  |  | LND |  | E | N | EN21 | 5503 | de | LND | 192,00 |  |
| EN24550310 |  | CA55 SR5503 - Final Static Calc |  | 124d | 2009-12-28 A | 2010-06-25 A | EN21550310 SS+5d, ER195503 FF | 100% |  | TKB-S [240 h] | EN24550310 | EN24550310 | 87B | N01M | 55 | N01M | 200 |  |  |  |  | LND |  | E | N | EN24 | 5503 | de | LND | 240,00 |  |
| EN265503 |  | CA55 SR5503 - Layout dwgs input for KM dwgs |  | 47d | 2010-04-27 A | 2010-07-02 A | EN24550310 FF+5d, F4030 FF+20d | 100% |  | TKB-S [240 h] | EN265503 | EN265503 | 87B | N01M | 55 | N01M | 200 |  |  |  |  | LND |  | E | N | EN26 | 5503 | st | LND | 240,00 |  |
| EN675503 |  | CA55 SR5503 - Grating Cut-Out drwgs |  | 28d | 2010-05-28 A | 2010-07-06 A | ER425503 FF | 100% |  | TKB-S [80 h] | EN675503 | EN675503 | 87B | N01M | 55 | N01M | 200 | 200 |  | C |  | LND |  | E | N | EN67 | 5503 | de | LND | 80,00 |  |
| EN27550305 |  | CA55 SR5503 - KM drwgs |  | 42d | 2010-07-07 A | 2010-09-02 A | EN265503, E3C170 FF, EN24550305 | 100% |  | KM Drwgs preparation by Cheljabinsk [85 t] | EN27550305 | EN27550305 | 87B | N01M | 55 | N01M | 200 |  |  |  |  | Chel |  | E | N | EN27 | 5503 | de | LND | 0,00 |  |
| EN645503 |  | CA55 SR5503 - Check Grating Cut-Out drwgs |  | 2d | 2010-07-07 A | 2010-07-08 A | EN675503 | 100% |  |  | EN645503 | EN645503 | 87B | N01M | 55 | N01M | 200 | 200 |  | C |  | LEI |  | E | N | EN67 | 5503 | de | LND |  |  |
| EN685503 |  | CA55 SR5503 - Grating Fabrication drwgs |  | 20d | 2010-07-09 A | 2010-08-05 A | EN645503, EN675503 | 100% |  |  | EN685503 | EN685503 | 87B | N01M | 55 | N01M | 200 | 200 |  | C |  | Chel |  | E | N | EN68 | 5503 | de | LND |  |  |
| EN27550310 |  | CA55 SR5503 - Check KM drwgs |  | 15d | 2010-09-03 A | 2010-09-23 A | EN27550305 | 100% |  |  | EN27550310 | EN27550310 | 87B | N01M | 55 | N01M | 200 |  |  |  |  | LND |  | E | N | EN27 | 5503 | de | LND |  |  |
| EN285503 |  | CA55 SR5503 - Shop dwgs(KMD) by Vendor |  | 46d | 2010-09-24 A | 2010-11-29 A | EN27550310 | 100% |  |  | EN285503 | EN285503 | 87B | N01M | 55 | N01M | 200 |  |  |  |  | Chel |  | E | N | EN28 | 5503 | de | LND |  |  |
| P3N01ME |  | CA55 SR5503 - Vendor Procurement |  | 55d | 2010-09-24 A | 2010-11-17 A | EN27550310 | 100% | TB26 - 2 - Manuf and Delivy |  | P3N01ME | P3N01ME | 860 | N01M | 55 | N01M | 200 | 200 | 400 | P | DEL | Chel | 0 | P | N | PN25 | 5503 | SS | LND |  |  |
| P3N01ML |  | CA55 SR5503 - Vendor Fabrication |  | 58d | 2010-11-27 A | 2011-01-26 A | EN285503 SS+45d, P3N01ME SS+20d | 100% | TB26 - 2 - Manuf and Delivy |  | P3N01ML | P3N01ML | 860 | N01M | 55 | N01M | 200 | 200 | 400 | P | DEL | Chel | 0 | P | N | PN26 | 5503 | SS | LND |  |  |
| P3N01MP |  | CA55 SR5503 - Transport to Site |  | 10d | 2011-01-27 A | 2011-02-05 A | P3N01ML | 100% | TB26 - 2 - Manuf and Delivy | Piperacks, Main Structures (Delivery) [85 t]; Ladders & Platforms (Delivery) [3 t] | P3N01MP | P3N01MP | 860 | N01M | 55 | N01M | 200 | 200 | 400 | P |  | Chel | 0 | P | N | PN28 | 5503 | SS | LND | 0,00 |  |
| P3N01MN |  | CA55 SR5503 - Goods arrived at Site | milestone | 0d | 2011-02-05 A | 2011-02-05 A | P3N01MP FF | 100% | TB26 - 2 - Manuf and Delivy |  | P3N01MN | P3N01MN | 860 | N01M | 55 | N01M | 200 | 200 | 400 | P |  | Chel | L2 | P | N | PN29 | 5503 | M | LND |  | CA55 SR5503 (N01M) - Прибытие товара на площадку |

| ID | WBS | Activity | Type | Duration | Start | Finish | Predecessors | Complete | Remaining | Planned start | Planned finish | Total float | Free float | Calendar | Resources | UDF_SAVE ACTID | UDF_SAVE ACT ID | Department | Type of Work | Constr. Area | Inquiry/Order No | PMT-Area | PMT-Schedule Org | PMT-Discipline | PMT-Phase | PMT-Doc. Type | PMT-Respons. | Zeigen/n. Zeigen | WBS Phase | WBS Discipline | WBS Type of Work | WBS Objects | IMS | UPT | TB26 Ressource Budget |
| --- | --- | --- | --- | --- | --- | --- | --- | --- | --- | --- | --- | --- | --- | --- | --- | --- | --- | --- | --- | --- | --- | --- | --- | --- | --- | --- | --- | --- | --- | --- | --- | --- | --- | --- | --- |
|  | 56 | **56 CA56 - Piperack (between CA17/31/55)** |  |  | 2010-11-06 | 2011-04-09 |  |  |  |  |  |  |  |  |  |  |  |  |  |  |  |  |  |  |  |  |  |  |  |  |  |  |  |  |  |
|  | 5601 | **(New WBS)** |  |  | 2010-11-06 | 2011-04-09 |  |  |  |  |  |  |  |  |  |  |  |  |  |  |  |  |  |  |  |  |  |  |  |  |  |  |  |  |  |
|  | N | **N Structural Steel** |  |  | 2010-11-06 | 2011-04-09 |  |  |  |  |  |  |  |  |  |  |  |  |  |  |  |  |  |  |  |  |  |  |  |  |  |  |  |  |  |
| P3N01JE |  | CA56 SR5601 - Vendor Procurement |  | 35d | 2010-11-06 A | 2010-12-10 A | EN27560110 | 100% |  |  |  |  |  | TB26 - 2 - Manuf and Delivy |  | P3N01JE | P3N01JE | 860 | N01J | 56 | N01J | 200 | 200 | 400 | P | DEL | Chel | 0 | P | N | PN25 | 5601 | SS | LND |  |
| P3N01JL |  | CA56 SR5601 - Vendor Fabrication |  | 104d | 2010-12-14 A | 2011-03-30 A | EN285601 SS+25d, P3N01JE SS+20d | 100% |  |  |  |  |  | TB26 - 2 - Manuf and Delivy |  | P3N01JL | P3N01JL | 860 | N01J | 56 | N01J | 200 | 200 | 400 | P | DEL | Chel | 0 | P | N | PN26 | 5601 | SS | LND |  |
| P3N01JP |  | CA56 SR5601 - Transport to Site |  | 10d | 2011-03-31 A | 2011-04-09 A | P3N01JL | 100% |  |  |  |  |  | TB26 - 2 - Manuf and Delivy | Piperacks, Main Structures (Delivery) [75 t]; Ladders & Platforms (Delivery) [4 t] | P3N01JP | P3N01JP | 860 | N01J | 56 | N01J | 200 | 200 | 400 | P |  | Chel | 0 | P | N | PN28 | 5601 | SS | LND | 0,00 |
| P3N01JN |  | CA56 SR5601 - Goods arrived at Site | milestone | 0d | 2011-04-09 A | 2011-04-09 A | P3N01JP FF, P3N100 FF | 100% |  |  |  |  |  | TB26 - 2 - Manuf and Delivy |  | P3N01JN | P3N01JN | 860 | N01J | 56 | N01J | 200 | 200 | 400 | P |  | Chel | L2 | P | N | PN29 | 5601 | M | LND |  |
|  | NO CA | **No Constr. Area** |  |  | 2007-12-10 | 2012-02-24 |  |  |  |  |  |  |  |  |  |  |  |  |  |  |  |  |  |  |  |  |  |  |  |  |  |  |  |  |  |
|  | NO WBS Objects | **No WBS Objects** |  |  | 2007-12-10 | 2012-02-24 |  |  |  |  |  |  |  |  |  |  |  |  |  |  |  |  |  |  |  |  |  |  |  |  |  |  |  |  |  |
|  | N | **N Structural Steel** |  |  | 2010-07-01 | 2011-08-19 |  |  |  |  |  |  |  |  |  |  |  |  |  |  |  |  |  |  |  |  |  |  |  |  |  |  |  |  |  |
| P3N100 |  | Structural Steel PO/Fabr./Transport to Site | level of effort | 294d | 2010-07-01 A | 2011-08-19 A | P3N01L SS | 100% |  |  |  |  |  |  |  | P3N100 | P3N100 | 008 |  |  |  |  |  |  | P |  | LND | M1 | P | N |  |  | SS | LND |  |
|  | B | **B Mechanical - Stationary Equipment** |  |  | 2007-12-10 | 2011-10-18 |  |  |  |  |  |  |  |  |  |  |  |  |  |  |  |  |  |  |  |  |  |  |  |  |  |  |  |  |  |
| P3B100 |  | Mechanical Equipment PO/Fabr./Transport to Site | level of effort | 1393d | 2007-12-10 A | 2011-10-18 | P3ALL1A SS, P3ALL2A SS, P3A05A SS, P3A08A SS, P3M01A SS | 46% | 48d |  |  | -9d | 0d | TB26 - 2 - Manuf and Delivy-3 |  | P3B100 | P3B100 | 008 |  |  |  |  |  |  | P |  | LND | M1 | P | B |  |  | E | LND |  |
| P3B110 |  | Reactors arrived at Site | milestone | 0d | 2010-08-01 A | 2010-08-01 A | P3ALL1S1 FF, P3ALL1S2 FF | 100% |  |  |  |  |  | TB26 - 2 - Manuf and Delivy |  | P3B110 | P3B110 | 008 |  |  |  |  |  |  | P |  | LND | M1 | P | B |  |  | E | LND |  |
| P3B120 |  | Purge Columns arrived at Site | milestone | 0d | 2010-08-02 A | 2010-08-02 A | P3ALL2S FF | 100% |  |  |  |  |  | TB24 - 3 - Construct-normal |  | P3B120 | P3B120 | 008 |  |  |  |  |  |  | P |  | LND | M1 | P | B |  |  | E | LND |  |
| P3B170 |  | Aluminium Silos arrived at Site 1st Lot | milestone | 0d | 2010-08-23 A | 2010-08-23 A | P3ALL4S1 FF | 100% |  |  |  |  |  | TB24 - 3 - Construct-normal |  | P3B170 | P3B170 | 008 |  |  |  |  |  |  | P |  | LND | M1 | P | B |  |  | E | LND |  |
| P3B160 |  | Offgas Compressors arrived at Site | milestone | 0d | 2011-01-17 A | 2011-01-17 A | P3M03S1 FF | 100% |  |  |  |  |  | TB24 - 3 - Construct-normal |  | P3B160 | P3B160 | 008 |  |  |  |  |  |  | P |  | LND | M1 | P | B |  |  | E | LND |  |
| P3B150 |  | Recycle Gas Compressors arrived at Site | milestone | 0d | 2011-01-17 A | 2011-01-17 A | P3M02S1 FF | 100% |  |  |  |  |  | TB24 - 3 - Construct-normal |  | P3B150 | P3B150 | 008 |  |  |  |  |  |  | P |  | LND | M1 | P | B |  |  | E | LND |  |
| P3B180 |  | PRU arrived at Site | milestone | 0d | 2011-10-14 | 2011-10-14 | P3U12S FF |  |  |  |  | -88d | 14d | TB26 - 2 - Manuf and Delivy-3 |  | P3B180 | P3B180 | 008 |  |  |  |  |  |  | P |  | LND | M1 | P | B |  |  | E | LND |  |
|  | R | **R Piping** |  |  | 2010-02-23 | 2011-10-06 |  |  |  |  |  |  |  |  |  |  |  |  |  |  |  |  |  |  |  |  |  |  |  |  |  |  |  |  |  |
| P3R100 |  | AG Piping PO/Fabr./Transport to Site | level of effort | 294d | 2010-02-23 A | 2011-04-19 A | P3R06CL SS, P3R06DL SS, P3R06AL SS, P3R06L SS, P3R06BL SS, P3R04AL SS | 100% |  |  |  |  |  |  |  | P3R100 | P3R100 | 008 |  |  |  |  |  |  | P |  | LND | M1 | P | R |  |  | PI | LND |  |
| P3R110 |  | UG Piping PO/Fabr./Transport to Site | level of effort | 345d | 2010-06-05 A | 2011-10-06 | P3R02BL SS, P3R02L SS, P3R02AL SS, P3R01L SS | 40% | 25d | 2010-06-07 | 2011-10-06 | 16d | 0d |  |  | P3R110 | P3R110 | 008 |  |  |  |  |  |  | P |  | LND | M1 | P | R |  |  | PI | LND |  |
|  | E | **E Electrical** |  |  | 2008-09-26 | 2011-11-09 |  |  |  |  |  |  |  |  |  |  |  |  |  |  |  |  |  |  |  |  |  |  |  |  |  |  |  |  |  |
| P3E100 |  | Electrical PO/Fabr./Transport to Site | level of effort | 787d | 2008-09-26 A | 2011-11-09 | P3E04L SS | 40% | 48d |  |  | 308.5d | 0d |  |  | P3E100 | P3E100 | 008 |  |  |  |  |  |  | P |  | LND | M1 | P | E |  |  | ELE | LND |  |

Notes:
- P3N01JN: UDF_Actictity Name (Russia): CA56 SR5601 (N01J) - Прибытие товара на площадку
- P3N100: UDF_Actictity Name (Russia): Заказ конструкционной стали/изготовление/транспортировка на площадку
- P3B100: UDF_Actictity Name (Russia): Заказ мех.оборудования/изготовление/транспортировка на площадку
- P3B110: UDF_Actictity Name (Russia): Поступление реакторов на площадку
- P3B120: UDF_Actictity Name (Russia): Поступление продувных колонн на площадку
- P3B170: UDF_Actictity Name (Russia): Поступление алюминиевых силосов на площадку
- P3B160: UDF_Actictity Name (Russia): Поступление компрессоров отходящего газа на площадку
- P3B150: UDF_Actictity Name (Russia): Поступление компрессоров рециркулирующего газа на площадку
- P3B180: UDF_Actictity Name (Russia): Поступление мембранной установки извлечения пропилена на площадку
- P3R100: UDF_Actictity Name (Russia): Заказ электрики/изготовление/транспортировка на площадку
- P3R110: UDF_Actictity Name (Russia): Заказ электрики/изготовление/транспортировка на площадку
- P3E100: UDF_Actictity Name (Russia): Заказ электрики/изготовление/транспортировка на площадку

| ID | WBS | Activity | Type | Duration | Start | Finish | Predecessors | Remaining | Total float | Free float | UDF_Actictity Name (Russia) | UDF_SAVE ACTID | UDF_SAVE ACT ID | Department | PMT-Phase | PMT-Respons. | Zeigen/n. Zeigen | WBS Phase | WBS Discipline | IMS | UPT |
| --- | --- | --- | --- | --- | --- | --- | --- | --- | --- | --- | --- | --- | --- | --- | --- | --- | --- | --- | --- | --- | --- |
|  | J | **J Instrumentation** |  |  | 2009-12-22 | 2012-02-24 |  |  |  |  |  |  |  |  |  |  |  |  |  |  |  |
| P3J100 |  | Instrumentation PO/Fabr./Transport to Site | level of effort | 555d | 2009-12-22 A | 2012-02-24 | P3J02L SS, P3J01L SS, P3J02BL SS, P3J02DL SS | 124d | 129d | 0d | Заказ КИП/изготовление/транспортировка на площадку | P3J100 | P3J100 | 008 | P | LND | M1 | P | J | INS | LND |
|  | A | **A** |  |  |  |  |  |  |  |  |  |  |  |  |  |  |  |  |  |  |  |
|  | T | **Template per Discipline** |  |  |  |  |  |  |  |  |  |  |  |  |  |  |  |  |  |  |  |
|  | 0B | **General Activities** |  |  |  |  |  |  |  |  |  |  |  |  |  |  |  |  |  |  |  |
|  | C | **Civil Work** |  |  |  |  |  |  |  |  |  |  |  |  |  |  |  |  |  |  |  |
|  | N | **Structural Steel** |  |  |  |  |  |  |  |  |  |  |  |  |  |  |  |  |  |  |  |
|  | H | **HVAC** |  |  |  |  |  |  |  |  |  |  |  |  |  |  |  |  |  |  |  |
|  | U | **Package Units** |  |  |  |  |  |  |  |  |  |  |  |  |  |  |  |  |  |  |  |
|  | B | **Mechanical - Stationary Equipment** |  |  |  |  |  |  |  |  |  |  |  |  |  |  |  |  |  |  |  |
|  | M | **Mechanical - Rotating Equipment** |  |  |  |  |  |  |  |  |  |  |  |  |  |  |  |  |  |  |  |
|  | R | **Piping** |  |  |  |  |  |  |  |  |  |  |  |  |  |  |  |  |  |  |  |
|  | E | **Electrical** |  |  |  |  |  |  |  |  |  |  |  |  |  |  |  |  |  |  |  |
|  | J | **Instrumentation** |  |  |  |  |  |  |  |  |  |  |  |  |  |  |  |  |  |  |  |
|  | S | **Safety & Environment** |  |  |  |  |  |  |  |  |  |  |  |  |  |  |  |  |  |  |  |
|  | W | **Painting** |  |  |  |  |  |  |  |  |  |  |  |  |  |  |  |  |  |  |  |
|  | V | **Insulation** |  |  |  |  |  |  |  |  |  |  |  |  |  |  |  |  |  |  |  |
|  | Template NEW | **Template NEW** |  |  |  |  |  |  |  |  |  |  |  |  |  |  |  |  |  |  |  |
|  | 0B | **0B General Activities** |  |  |  |  |  |  |  |  |  |  |  |  |  |  |  |  |  |  |  |
|  | A | **A Project Management** |  |  |  |  |  |  |  |  |  |  |  |  |  |  |  |  |  |  |  |
|  | P | **P Process** |  |  |  |  |  |  |  |  |  |  |  |  |  |  |  |  |  |  |  |
|  | L | **L Plant Design** |  |  |  |  |  |  |  |  |  |  |  |  |  |  |  |  |  |  |  |
|  | C | **C Civil** |  |  |  |  |  |  |  |  |  |  |  |  |  |  |  |  |  |  |  |
|  | N | **N Structural Steel** |  |  |  |  |  |  |  |  |  |  |  |  |  |  |  |  |  |  |  |
|  | H | **H HVAC** |  |  |  |  |  |  |  |  |  |  |  |  |  |  |  |  |  |  |  |
|  | U | **U Package Units** |  |  |  |  |  |  |  |  |  |  |  |  |  |  |  |  |  |  |  |
|  | B | **B Mechanical - Stationary Equipment** |  |  |  |  |  |  |  |  |  |  |  |  |  |  |  |  |  |  |  |
|  | E | **E Electrical** |  |  |  |  |  |  |  |  |  |  |  |  |  |  |  |  |  |  |  |
|  | J | **J Instrumentation** |  |  |  |  |  |  |  |  |  |  |  |  |  |  |  |  |  |  |  |
|  | M | **M Mechanical - Rotating Equipment** |  |  |  |  |  |  |  |  |  |  |  |  |  |  |  |  |  |  |  |
|  | R | **R Piping** |  |  |  |  |  |  |  |  |  |  |  |  |  |  |  |  |  |  |  |
|  | S | **S Safety & Environment** |  |  |  |  |  |  |  |  |  |  |  |  |  |  |  |  |  |  |  |
|  | Q | **Q Quality Planning/ Qualtity Assurance** |  |  |  |  |  |  |  |  |  |  |  |  |  |  |  |  |  |  |  |

## Activity codes

| Code | Value | Meaning |
| --- | --- | --- |
| Constr. Area | 00 | Construction Areas - General |
| Constr. Area | 0A | Advanced Detailengineering All Areas |
| Constr. Area | 0C | Construction Milestones Disciplines |
| Constr. Area | 0D | Detailengineering All Areas |
| Constr. Area | 0E | Engineering Milestones Disciplines |
| Constr. Area | 0F | FEED Phase All Areas |
| Constr. Area | 0P | Procurement Milestones Disciplines |
| Constr. Area | 10 | CA10 - Propylene Recovery Unit Area |
| Constr. Area | 11 | CA11 - Offgas Compression Line 1 + 2 |
| Constr. Area | 12 | CA12 - Polymerization Line 1 |
| Constr. Area | 13 | CA13 - Polymerization Line 2 |
| Constr. Area | 14 | CA14 - Flare Area |
| Constr. Area | 15 | CA15 - Instrument Air Buffer Vessel |
| Constr. Area | 16 | CA16 - Substation / RIE's |
| Constr. Area | 17 | CA17 - Extruder Pack / Additive Handling-Line1/2 |
| Constr. Area | 18 | CA18 - Central Chiller Unit Area |
| Constr. Area | 31 | CA31 - Storage / Packaging and Shipping Building |
| Constr. Area | 41 | CA41 - Control Building |
| Constr. Area | 51 | CA51 - Piperack (btw. CA11-15/17/19/52/53/54) |
| Constr. Area | 52 | CA52 - Piperack (between CA11/51) |
| Constr. Area | 53 | CA53 - Piperack (between CA14/51) |
| Constr. Area | 54 | CA54 - Piperack (between CA15/16/51/55) |
| Constr. Area | 55 | CA55 - Piperack (between CA16/17/56) |
| Constr. Area | 56 | CA56 - Piperack (between CA17/31/55) |
| Constr. Area | 90 | CA90 - U/G Systems / Battery Limit |
| Constr. Area | 96 | Concrete Paving |
| Department | 007 | Engineering |
| Department | 008 | Procurement |
| Department | 858 | Process Design CP/CB |
| Department | 860 | Procurement - KB |
| Department | 867 | Rotating Equipment - TAM |
| Department | 869 | Pressure Vessels, Tanks, Package Units - TAA |
| Department | 86A | Instrumentation - General- TAP |
| Department | 86B | Instrumentation -Field Instruments- TAP |
| Department | 86C | Instrumentation -Automation Systems- TAP |
| Department | 86E | Instrumentation -Construction Engineering- TAP |
| Department | 871 | Plant Safety -TAS |
| Department | 872 | Stress Calculation - TKF |
| Department | 873 | Pipe Classes & piping Material - TKR |
| Department | 874 | Electrical by - Linde -TAE |
| Department | 876 | Plant Design - TKK |
| Department | 87A | Civil Engineering - TKBB |
| Department | 87B | Steel Structures TKBS |
| Department | 87C | HVAC + Plumbing TKBH |
| Department | 87D | Electrical Main Equipment by - Linde - TAE |
| Department | 87E | Electrical Bulk Material by Construction Company |
| Department | 87F | Electrical by Special Contractor |
| Department | 87G | Electrical by U/I/O |
| Department | 883 | Qualty Planning & Quality Assurance |
| Department | 887 | Process - CP |
| Department | 915 | Project Execution - CA |
| Department | 916 | Sales - CV |
| Department | 924 | Operational Design - CB |
| Department | 932 | Project Controls - KP |
| Department | 934 | Construction Engineering- TME |
| Department | 956 | Contract Management - KV |
| Department | G | General Milestones |
| Department | I | INEOS SCHEDULED DELIVERABLES |
| Department | L | FEED Contractors Requirements from PMT/Licensor |
| Department | L1 | Pre-kick-off agreed deliverables |
| Department | L2 | Standardization Program/SPA |
| Department | L3 | Add. Requirements FEED Contractor |
| Department | L4 | Cost Estimating |
| Department | N | Product Handling |
| IMS | 00 | General |
| IMS | 1 | Piping Design |
| IMS | 2 | 60% Model Review |
| IMS | 3 | 90% Model Review |
| IMS | 4 | Issue UG Isometrics RFC |
| IMS | 5 | Issue AG Isometrics Review |
| IMS | AG | Aboveground |
| IMS | B | Bulk |
| IMS | C | CONSTRUCTION |
| IMS | CM | Commissioning |
| IMS | CW | Civil Works |
| IMS | E | Equipment (Static, Rotary, Packages) |
| IMS | ELE | Electrical |
| IMS | EQ | Install Equipment |
| IMS | I | Instrument Design |
| IMS | INS | Instrumentation |
| IMS | IT | Itemized |
| IMS | M | Main Steel Structure at Site |
| IMS | MC | Mechanical Completion |
| IMS | ME | Mechanical |
| IMS | ML | MANAGEMENT, MILESTONES & COORDINATION |
| IMS | OTH | Engineering (others) |
| IMS | P | Piling |
| IMS | PI | Piping |
| IMS | PL | Piping |
| IMS | PRE | Precast Drwgs RFC |
| IMS | S | Secondary Steel Structure at Site |
| IMS | SA | Safety Equipment |
| IMS | SS | Structural Steel at Site |
| IMS | SU | Ready for Start Up |
| IMS | UG | Underground |
| IMS | ar | Building RFC |
| IMS | ci | Civil Works Contractor |
| IMS | cq | Foundations & Underground RFC |
| IMS | cs | Concrete Structure |
| IMS | de | Civil, Structural & Architectural Design |
| IMS | e&i | E&I Contractor |
| IMS | hva_as | HVAC at Site |
| IMS | mi | Mechanical Installation Contractor |
| IMS | st | Release Steel Models RFC |
| Inquiry/Order No | 000 | Utilities |
| Inquiry/Order No | 020 | Package Units |
| Inquiry/Order No | 210 | Unit 210 |
| Inquiry/Order No | 211 | Unit 211 |
| Inquiry/Order No | 212 | Unit 212 |
| Inquiry/Order No | 213 | Unit 213 |
| Inquiry/Order No | 214 | Unit 214 |
| Inquiry/Order No | 215 | Unit 215 |
| Inquiry/Order No | 218 | Unit 218 |
| Inquiry/Order No | 2AC2600 | AG Piping Ball-,Gate-,Globe-,Butterfly Valves |
| Inquiry/Order No | 2AC2690 | UG Piping Post Indicator Valves |
| Inquiry/Order No | 2AC5490 | AG Piping Piston RAM Valves |
| Inquiry/Order No | 2AJ2610 | Ball Valves |
| Inquiry/Order No | 2AJ2620 | Ball Valves Discharge |
| Inquiry/Order No | 2AJ2660 | PCV Valves |
| Inquiry/Order No | 2AJ3000 | Knife Valves |
| Inquiry/Order No | 2AJ3020 | ON/OFF Plug Valves |
| Inquiry/Order No | 2AJ3030 | Control Valves |
| Inquiry/Order No | 2AJ3090 | Butterfly Valves |
| Inquiry/Order No | 2DC8440 | Reactors w. Agitators R-21201, R-22201 |
| Inquiry/Order No | 2DC8460 | Offgas Compressor Pack. K-21301,K-22301 |
| Inquiry/Order No | 2DC8480 | Extruder Package EX-21401, EX-22401 |
| Inquiry/Order No | 2DC8490 | Recycle Gas Compressor K-21201 A/B, K-22201A/B |
| Inquiry/Order No | 2DC8500 | Purge Columns + Reactor Overhead Separators |
| Inquiry/Order No | 2DC8560 | Purge Col. Vent-/Gas Exp.-/Offgas Compr. Filter |
| Inquiry/Order No | 2DC8590 | Offgas Cyclone&Receiver CY-21202, CY-22202 |
| Inquiry/Order No | 2DC8640 | Reactor Fines Eductor MI-21102, MI-22202 |
| Inquiry/Order No | 2DC8910 | Reactor Seal Oil Package |
| Inquiry/Order No | 2DC8940 | Rotary Feeders |
| Inquiry/Order No | 2DC8990 | Conveying System (Zeppelin) |
| Inquiry/Order No | 2DC9000 | Silo's and Blenders |
| Inquiry/Order No | 2DC9010 | Mobile FFS Bagging System BG-31201 |
| Inquiry/Order No | 2DC9020 | Pallet Packaging & Palletizing Equipment |
| Inquiry/Order No | 2DC9060 | Scales |
| Inquiry/Order No | 2DC9080 | Electrical Heater |
| Inquiry/Order No | 2DC9110 | Reactor Overhead Condensor |
| Inquiry/Order No | 2DC9170 | Vent Collection & Vacuum Cleaning System |
| Inquiry/Order No | 2DC9450 | Large Pressure Vessels |
| Inquiry/Order No | 2DC9630 | Catalyst Drum Roller |
| Inquiry/Order No | 2DC9640 | Big Bag Powder Loading Station |
| Inquiry/Order No | 2DC9820 | Additive Feed System PK-21401 A-F |
| Inquiry/Order No | 2DC9840 | Polymer Water Basket |
| Inquiry/Order No | 2DD0330 | Flare Package |
| Inquiry/Order No | 2DD8530 | Pressure Equipment |
| Inquiry/Order No | 2EB5180 | Electrical Heat Tracing |
| Inquiry/Order No | 2EB5450 | Diesel Generator |
| Inquiry/Order No | 2EB5610 | UPS/DC- System |
| Inquiry/Order No | 2EB5620 | Power Transformer |
| Inquiry/Order No | 2EB5630 | LV-Switchgears/Freq.Conv./Softstarter/Capacitators/P.Controller |
| Inquiry/Order No | 2EB5640 | MV-Switchgears |
| Inquiry/Order No | 2EB6080 | CCTV System |
| Inquiry/Order No | 2EB6110 | Electrical Power MV Cable |
| Inquiry/Order No | 2EB6120 | Local Switches / Push Button Station EDG |
| Inquiry/Order No | 2EB6130 | Aviation Lights |
| Inquiry/Order No | 2EB6150 | LV Distribution/Lighting Panels |
| Inquiry/Order No | 2EB6200 | Electrical Power LV Cable |
| Inquiry/Order No | 2EB6210 | Cable Glands |
| Inquiry/Order No | 2JD7280 | Coriolis Mass Flowmeters |
| Inquiry/Order No | 2JD7320 | Integral Orifice / Orifice / Venturi Tubes |
| Inquiry/Order No | 2JD7330 | Variable Area Flowmeter (Rotameter) |
| Inquiry/Order No | 2JD7520 | Machine Protection-/Conditiong. Monitoring Sys. |
| Inquiry/Order No | 2JD7540 | Nuclear Level Measurement |
| Inquiry/Order No | 2JD7560 | Analyser Integrated System |
| Inquiry/Order No | 2JD8440 | Radar Level Measurements |
| Inquiry/Order No | 2JD8450 | PLC Network |
| Inquiry/Order No | 2JD8470 | Magnetic Level Gauges |
| Inquiry/Order No | 2JD8480 | Pressure Gauges |
| Inquiry/Order No | 2JD8500 | Ultrasonic Flowmeters |
| Inquiry/Order No | 2JD8690 | Pressure Transmitter |
| Inquiry/Order No | 2JD8700 | Temperature Gauges |
| Inquiry/Order No | 2JD8710 | Temperature Transmitter |
| Inquiry/Order No | 2JD8720 | Thermowell and Elements |
| Inquiry/Order No | 2JD8840 | Diff.- Pressure Transmitter |
| Inquiry/Order No | 2JD8960 | Pressure Switches |
| Inquiry/Order No | 2JD9190 | Vibration Fork Level Switch |
| Inquiry/Order No | 2JD9220 | DCS / SIS |
| Inquiry/Order No | 2JD9260 | Vortex Flowmeters |
| Inquiry/Order No | 2JD9450 | Winterization Enclosures |
| Inquiry/Order No | 2JD9480 | Sample Boards |
| Inquiry/Order No | 2JD9490 | Local Operation Panels / Hand Switches and Alarms |
| Inquiry/Order No | 2JD9500 | Local Indicator Panels |
| Inquiry/Order No | 2JD9530 | Instrument Cable |
| Inquiry/Order No | 2JD9620 | Junction Boxes |
| Inquiry/Order No | 2JD9640 | Special Cabinets |
| Inquiry/Order No | 2KB2429 | Reactor Gear Motors |
| Inquiry/Order No | 2KB4240 | Propylene Recovery Unit PK-21301 |
| Inquiry/Order No | 2KB4290 | Reactor Agitator Gear Unit AG-21201, AG-22201 |
| Inquiry/Order No | 2KB4360 | Gas Bleed Compressor Pack. (K-21801) |
| Inquiry/Order No | 2KB4420 | Unloading Arms |
| Inquiry/Order No | 2KB4660 | Instrument Air Compressor |
| Inquiry/Order No | 2KB4740 | Overhead Cranes > 32t |
| Inquiry/Order No | 2KB9850 | PCW Cooler |
| Inquiry/Order No | 2KB9890 | Chiller Unit |
| Inquiry/Order No | 2M00020 | Structural Steel Fabrication Subcontract |
| Inquiry/Order No | 2MD6870 | Civil & Construction Subcontract |
| Inquiry/Order No | 2MD6880 | Mechanical Subcontract |
| Inquiry/Order No | 2MD6890 | E&I Subcontract |
| Inquiry/Order No | 2MD6950 | Piling Subcontract |
| Inquiry/Order No | 2PA6540 | Reactor Tepid Water Pump P-21203, P-22203 |
| Inquiry/Order No | 2PA6550 | Reactor Quench Pump P-21201, P-22201 |
| Inquiry/Order No | 2PA6670 | Catalyst Feed Pumps |
| Inquiry/Order No | 2PA6680 | Unloading Pumps |
| Inquiry/Order No | 2PA6690 | Catalyst/Co-Catalyst Waste Pumps |
| Inquiry/Order No | 2PA6720 | Condensate / Service Water Pumps |
| Inquiry/Order No | 2PA6900 | Submersible Pumps |
| Inquiry/Order No | 2RE1350 | UG Piping - GFK Piping Material |
| Inquiry/Order No | 2RE1800 | AG Pipes CS |
| Inquiry/Order No | 2RE1810 | AG Pipes SS |
| Inquiry/Order No | 2RE1820 | AG Fittings CS |
| Inquiry/Order No | 2RE1830 | AG Fittings SS |
| Inquiry/Order No | 2RE1840 | AG Flanges CS/SS |
| Inquiry/Order No | 2RE2190 | Standard Pipe Supports |
| Inquiry/Order No | 2RE2220 | Air Manifolds / Hoses |
| Inquiry/Order No | 2RE2240 | UG Piping - Cast Iron Material |
| Inquiry/Order No | 2RE2290 | UG Piping - HDPE Piping Material |
| Inquiry/Order No | 2RE2380 | Gaskets |
| Inquiry/Order No | 2RE2610 | Bolting Material |
| Inquiry/Order No | 2RE3370 | Spring Supports |
| Inquiry/Order No | 2SI1730 | Water Spray Deluge System |
| Inquiry/Order No | 2SI1740 | Sprinkler System |
| Inquiry/Order No | 2SI1750 | Rupture Disks |
| Inquiry/Order No | 2SI1760 | Safety Relief Valves |
| Inquiry/Order No | 2SI1770 | Gas Extinguishing System |
| Inquiry/Order No | 2SI1810 | Hydrants |
| Inquiry/Order No | 2SI1880 | Flame Arrestors |
| Inquiry/Order No | 2SI1890 | Minor FF Equipment |
| Inquiry/Order No | 2SI1930 | Monitors |
| Inquiry/Order No | 400 | All Units / Package Units |
| Inquiry/Order No | A02D | Vessels - Central Chiller Unit |
| Inquiry/Order No | A25 | Safety Showers |
| Inquiry/Order No | D01 | General Cargo Subcontract |
| Inquiry/Order No | E09 | Lighting & Power Sockets (E+I SUB) |
| Inquiry/Order No | E11 | Earthing (E+I SUB) |
| Inquiry/Order No | E12 | Fire Detection System |
| Inquiry/Order No | E16 | Electrical Cable Tray Sys. (E+I SUB) |
| Inquiry/Order No | H01 | HVAC Equipment |
| Inquiry/Order No | J09 | Instr.Cable Trays & Bulk Material |
| Inquiry/Order No | J18 | Weighing for Vessels |
| Inquiry/Order No | N01 | Structural Steel Erection Subcontract |
| Inquiry/Order No | N01A | Pipe Racks - SR5101 |
| Inquiry/Order No | N01B | Pipe Racks - SR5102 |
| Inquiry/Order No | N01C | Pipe Racks - SR5103 |
| Inquiry/Order No | N01D | Pipe Racks - SR5104 |
| Inquiry/Order No | N01E | Pipe Racks - SR5201 |
| Inquiry/Order No | N01F | Pipe Racks - SR5301 |
| Inquiry/Order No | N01G | Pipe Racks - SR5401 |
| Inquiry/Order No | N01H | Pipe Racks - SR5402 |
| Inquiry/Order No | N01I | Pipe Racks - SR5501 |
| Inquiry/Order No | N01J | Pipe Racks - SR5601 |
| Inquiry/Order No | N01L | Pipe Rack SR5502 |
| Inquiry/Order No | N01M | Pipe Rack SR5503 |
| Inquiry/Order No | N02" | SK3106 Supports CA31 |
| Inquiry/Order No | N02# | SK3105 Silo Staircase |
| Inquiry/Order No | N02$ | SK1306 Catalyst Bldg Line2 |
| Inquiry/Order No | N02* | SK1104 Offgas Compressor Filter Section |
| Inquiry/Order No | N021 | SK1701 Extruder Structure 1st Floor |
| Inquiry/Order No | N022 | SK1701 Extruder Structure 2nd Floor |
| Inquiry/Order No | N023 | SK1701 Extruder Structure 3rd Floor |
| Inquiry/Order No | N024 | SK1701 Extruder Structure 4th Floor |
| Inquiry/Order No | N025 | SK1701 Extruder Structure 5th Floor |
| Inquiry/Order No | N02A | SK1105 Structures inside Offgas Compressor Bldg |
| Inquiry/Order No | N02B | SK1601 Substation - Auxiliary/Platforms in-/outside |
| Inquiry/Order No | N02C | SK1401 Flare KO Drum Section |
| Inquiry/Order No | N02D | SK1201 Reactor Structure |
| Inquiry/Order No | N02E | SK1204 Connection Struct. to Teal Bldg Line1 |
| Inquiry/Order No | N02F | SK1205 Agitator Removeable Unit Line 1 |
| Inquiry/Order No | N02G | SK1301 Reactor Structure |
| Inquiry/Order No | N02H | SK1304 Connection Struct. to Teal Bldg Line2 |
| Inquiry/Order No | N02I | SK1303 Connect. Structure to Extruder Bldg |
| Inquiry/Order No | N02J | SK1305 Agitator Removeable Unit Line2 |
| Inquiry/Order No | N02K | SK1101 Offgas Compressor Bldg |
| Inquiry/Order No | N02M | Auxiliary/Monorails/Crane Structures inside Extruder Room |
| Inquiry/Order No | N02O | SK1705/09 Platforms/Frames inside Extrusion Building |
| Inquiry/Order No | N02P | SK1202 Teal Bldg Line1 |
| Inquiry/Order No | N02Q | SK1302 Teal Bldg Line2 |
| Inquiry/Order No | N02R | SK1206 Catalyst Bldg Line1 |
| Inquiry/Order No | N02S | SK1702 Extruder Building Entrance Hall |
| Inquiry/Order No | N02T | SK1703 Purge Bin Structure +94m |
| Inquiry/Order No | N02U | SK1704 Piperack inside Extrusion Building |
| Inquiry/Order No | N02V | SR1707 Connect. Piperack to CA12 |
| Inquiry/Order No | N02W | SR1708 Connect. Piperack to CA13 |
| Inquiry/Order No | N02X | SK1001 PRU Section |
| Inquiry/Order No | N02Y | SK3101 Silo Structure |
| Inquiry/Order No | N02Z | SK3104 Blower-/Truck Loading Section |
| Inquiry/Order No | N02~ | SK1801 Central Chiller Unit Structure |
| Inquiry/Order No | N02§ | SK1706 Extr Bldg Cladding Support Structure |
| Inquiry/Order No | N02Д | SK3103 Service Area |
| Inquiry/Order No | N02Ц | SK3102 Warehouse Section |
| Inquiry/Order No | N02Ь | SK1401 Flare Section |
| Inquiry/Order No | PP | PP Plant Design |
| Inquiry/Order No | R09A | Cycle Gas Expansion Joints |
| PMT-Area | 000 | Project |
| PMT-Area | 200 | Polypropylene Unit (PP) |
| PMT-Discipline | 001 | Project Management |
| PMT-Discipline | 002 | General |
| PMT-Discipline | 010 | Civil |
| PMT-Discipline | 015 | Structural |
| PMT-Discipline | 025 | Process |
| PMT-Discipline | 035 | HVAC |
| PMT-Discipline | 045 | Fire Protection |
| PMT-Discipline | 050 | Piping |
| PMT-Discipline | 055 | Mechanical |
| PMT-Discipline | 065 | Electrical |
| PMT-Discipline | 070 | Control Systems |
| PMT-Discipline | 080 | Health/Safety/Environmental |
| PMT-Discipline | 085 | Material Engineering |
| PMT-Discipline | 300 | Project Controls |
| PMT-Discipline | 400 | Procurement |
| PMT-Discipline | 500 | Construction |
| PMT-Doc. Type | DEL | Equipment Delivery |
| PMT-Doc. Type | DEV | Develop Dwgs/Spec/RFQ |
| PMT-Doc. Type | DFA | TDC Issue for Approval |
| PMT-Phase | 2 | Linde GATES |
| PMT-Phase | AD | Advanced Detailengineering |
| PMT-Phase | C | Construction |
| PMT-Phase | E | Engineering |
| PMT-Phase | F | FEED |
| PMT-Phase | P | Procurement |
| PMT-Respons. | AVR | 000 AVR Center Russia |
| PMT-Respons. | CC | Construction Company |
| PMT-Respons. | CDC | Civil Detail Design Contractors (Kaplan/Ipro/Vnipineft/Nipigaz) |
| PMT-Respons. | Chel | Cheljabinsk (Steel Fab. Contractor) |
| PMT-Respons. | INE | INEOS |
| PMT-Respons. | IPR | IPRO |
| PMT-Respons. | LEI | Linde India |
| PMT-Respons. | LND | LINDE |
| PMT-Respons. | LNI | Linde / Linde Indien |
| PMT-Respons. | LNK | Linde/IB KAPLAN |
| PMT-Respons. | LNZ | Linde/ Zeppelin |
| PMT-Respons. | OWN | Sibur/Tobolsk Polymer |
| PMT-Respons. | PMT | Sibur/Fluor |
| PMT-Respons. | SC | Special Contractor |
| PMT-Respons. | UIO | Utilities Infrastructure and Offsites |
| PMT-Respons. | YGW | Yokogawa - Feed Phase |
| PMT-Respons. | ZEP | ZEPPELIN |
| PMT-Schedule Org | 001 | Major Milestones |
| PMT-Schedule Org | 010 | Sibur/Tobolsk Polymer |
| PMT-Schedule Org | 200 | Polypropylene Unit (PP) |
| PMT-Stage | 3A | Stage 3A Basic Design |
| PMT-Stage | 3B | Detail Engineering (EPC) |
| Pro Unit/DocCode | 000 | General |
| Pro Unit/DocCode | 010 | Utilities |
| Pro Unit/DocCode | 020 | Package Units |
| Pro Unit/DocCode | 1000C01 | CA10 PRU Area - Layout Drwgs / Loads (IFD) |
| Pro Unit/DocCode | 1000C11 | CA10 PRU Area - General Drwgs & Documents |
| Pro Unit/DocCode | 1010C13 | CA10 PRU Area - Civil/Architect Layout Drwgs |
| Pro Unit/DocCode | 1010C14 | CA10 PRU Area - Static Calculation |
| Pro Unit/DocCode | 1010C16 | CA10 PRU Area - Piling Drwgs |
| Pro Unit/DocCode | 1010C21 | CA10 PRU Area - Formw/Reinforce drwgs AFC |
| Pro Unit/DocCode | 1100C01 | CA11 General - Layout Drwgs / Loads (IFD) |
| Pro Unit/DocCode | 1100C11 | CA11 General - General Drwgs & Documents |
| Pro Unit/DocCode | 1101C01 | CA11 Compr Bldg. - Layout Drwgs / Loads (IFD) |
| Pro Unit/DocCode | 1101C13 | CA11 C.Bldg. - Civil/Architect Layout Drwgs |
| Pro Unit/DocCode | 1101C14 | CA11 Compr Bldg. - Static Calculation |
| Pro Unit/DocCode | 1101C15 | CA11 Compr Bldg. - Fire Safety Survey Report |
| Pro Unit/DocCode | 1101C16 | CA11 C.Bldg. - Piling Drwgs |
| Pro Unit/DocCode | 1101C21 | CA11 Compr Bldg. - Drwgs Found./Base Plate |
| Pro Unit/DocCode | 1101C22 | CA11 Compr Bldg. - Drwgs Ground Level |
| Pro Unit/DocCode | 1101C31 | CA11 Compr Bldg. - Precast Drwgs |
| Pro Unit/DocCode | 1101C41 | CA11 Compr Bldg. - Architectural Detal Drwgs |
| Pro Unit/DocCode | 1101C53 | CA11 Compr Bldg. - Precast/Formw/Reinf Drwgs above Ground Level |
| Pro Unit/DocCode | 1101H21 | CA11 Compr Bldg. - Loads/Openings HVAC Systems |
| Pro Unit/DocCode | 1101H22 | CA11 Compr Bldg. - Calculations/Flow Diagrams HVAC Systems |
| Pro Unit/DocCode | 1101H23 | CA11 Compr Bldg. - HVAC Layout Drwgs AFC |
| Pro Unit/DocCode | 1101N51 | CA11 Compr Bldg. - Structural Steel Drwgs |
| Pro Unit/DocCode | 1110C01 | CA11 Compr Found. - Layout Drwgs/ Loads (IFD) |
| Pro Unit/DocCode | 1110C14 | CA11 Compr Found. - Static Calculation |
| Pro Unit/DocCode | 1110C21 | CA11 Compr Found. - Drwgs Foundation |
| Pro Unit/DocCode | 1111C01 | CA11 OffgComprFilt. - Layout Drwgs / Loads (IFD) |
| Pro Unit/DocCode | 1111C13 | CA11 OffgComprFilt. - Civil/Architect Layout Drw |
| Pro Unit/DocCode | 1111C14 | CA11 OffgComprFilt. - Static Calculation |
| Pro Unit/DocCode | 1111C16 | CA11 OffgComprFilt. - Piling Drwgs |
| Pro Unit/DocCode | 1111C21 | CA11 OffgComprFilt. - Drwgs Found./Base Plate |
| Pro Unit/DocCode | 1200C01 | CA12 General - Layout Drwgs / Loads (IFD) |
| Pro Unit/DocCode | 1200C11 | CA12 General - General Drwgs & Documents |
| Pro Unit/DocCode | 1201C01 | CA12 Reactor Str. - Layout Drwgs/ Loads (IFD) |
| Pro Unit/DocCode | 1201C13 | CA12 Reactor Str. - Civil/Architect Layout Drwgs |
| Pro Unit/DocCode | 1201C14 | CA12 Reactor Str. - Static Calculation |
| Pro Unit/DocCode | 1201C16 | CA12 Reactor Str. - Piling Drwgs |
| Pro Unit/DocCode | 1201C21 | CA12 Reactor Str. - Drwgs Found./Base Plate |
| Pro Unit/DocCode | 1201C32 | CA12 Reactor Str. - Drwgs Concrete Str. |
| Pro Unit/DocCode | 1202C01 | CA12 Teal Bldg. - Layout Drwgs/ Loads (IFD) |
| Pro Unit/DocCode | 1202C13 | CA12 Teal Bldg. - Civil/Architect Layout Drwgs |
| Pro Unit/DocCode | 1202C14 | CA12 Teal Bldg. - Static Calculation |
| Pro Unit/DocCode | 1202C15 | CA12 Teal Bldg. - Fire Safety Survey Report |
| Pro Unit/DocCode | 1202C16 | CA12 Teal Bldg - Piling Drwgs |
| Pro Unit/DocCode | 1202C21 | CA12 Teal Bldg - Drwgs Found. / Base Plate |
| Pro Unit/DocCode | 1202C22 | CA12 Teal Bldg. - Drwgs Ground Level |
| Pro Unit/DocCode | 1202C41 | CA12 Teal Bldg - Architetcural Detail Drwgs |
| Pro Unit/DocCode | 1202H21 | CA12 Teal Bldg - Loads/Openings HVAC Systems |
| Pro Unit/DocCode | 1202H22 | CA12 Teal Bldg - Calculations/Flow Diagrams HVAC Systems |
| Pro Unit/DocCode | 1202H23 | CA12 Teal Bldg - HVAC Layout Drwgs AFC |
| Pro Unit/DocCode | 1202N51 | CA12 Teal Bldg - Structural Steel Drwgs |
| Pro Unit/DocCode | 1204C01 | CA12 Conn.Teal S. - Layout Drwgs/ Loads (IFD) |
| Pro Unit/DocCode | 1204C13 | CA12 Conn.Teal S. - Civil/Architect Layout Drwgs |
| Pro Unit/DocCode | 1204C14 | CA12 Conn.Teal S. - Static Calculation |
| Pro Unit/DocCode | 1204C16 | CA12 Conn.Teal S. - Piling Drwgs |
| Pro Unit/DocCode | 1204C21 | CA12 Conn.Teal S. - Drwgs Found./Base Plate |
| Pro Unit/DocCode | 1204C53 | CA12 Conn.Teal S. - Precast Detail Formw/Reinf. Drwgs |
| Pro Unit/DocCode | 1205C01 | CA12 Agitator R.U. - Layout Drwgs/ Loads (IFD) |
| Pro Unit/DocCode | 1205C13 | CA12 Agitator R.U. - Civil/Architec Layout Drwgs |
| Pro Unit/DocCode | 1205C14 | CA12 Agitator R.U. - Static Calculation |
| Pro Unit/DocCode | 1205C16 | CA12 Agitator R.U. - Piling Drwgs |
| Pro Unit/DocCode | 1205C21 | CA12 Agitator R.U. - Drwgs Found. / Base Plate |
| Pro Unit/DocCode | 1206C01 | CA12 Catalyst Bldg - Layout Drwgs/ Loads (IFD) |
| Pro Unit/DocCode | 1206C13 | CA12 Catalyst Bldg - Civil/Architec Layout Drwgs |
| Pro Unit/DocCode | 1206C14 | CA12 Catalyst Bldg - Static Calculation |
| Pro Unit/DocCode | 1206C15 | CA12 Catalyst Bldg - Fire Safety Survey Report |
| Pro Unit/DocCode | 1206C16 | CA12 Catalyst Bldg - Piling Drwgs |
| Pro Unit/DocCode | 1206C21 | CA12 Catalyst Bldg - Drwgs Found. / Base Plate |
| Pro Unit/DocCode | 1206C22 | CA12 Catalyst Bldg - Drwgs Ground Level |
| Pro Unit/DocCode | 1206C23 | CA12 Catalyst Bldg - Drwgs 1st Level |
| Pro Unit/DocCode | 1206C24 | CA12 Catalyst Bldg - Drwgs 2nd Level |
| Pro Unit/DocCode | 1206C25 | CA12 Catalyst Bldg - Drwgs 3rd Level |
| Pro Unit/DocCode | 1206C41 | CA12 Catalyst Bldg - Architectural Detail Drwgs |
| Pro Unit/DocCode | 1206H21 | CA12 Catalyst Bldg - Loads/Openings HVAC Systems |
| Pro Unit/DocCode | 1206H22 | CA12 Catalyst Bldg - Calculations/Flow Diagrams HVAC Systems |
| Pro Unit/DocCode | 1206H23 | CA12 Catalyst Bldg - HVAC Layout Drwgs AFC |
| Pro Unit/DocCode | 1206N51 | CA12 Catalyst Bldg - Structural Steel Drwgs |
| Pro Unit/DocCode | 1210C01 | CA12 Other Ground Eq - Layout Drwgs/Loads (IFD) |
| Pro Unit/DocCode | 1210C14 | CA12 Other Ground Eq - Static Calculation |
| Pro Unit/DocCode | 1210C21 | CA12 Other Ground Eq - Drwgs Foundation |
| Pro Unit/DocCode | 1211C01 | CA12 R.G.Compr. - Layout Drwgs/ Loads (IFD) |
| Pro Unit/DocCode | 1211C14 | CA12 R.G.Compr. - Static Calculation |
| Pro Unit/DocCode | 1211C16 | CA12 R.G.Compr. - Piling Drwgs |
| Pro Unit/DocCode | 1211C21 | CA12 R.G.Compr. - Drwgs Foundation |
| Pro Unit/DocCode | 1212C01 | CA12 B.B.Compr. - Layout Drwgs/ Loads (IFD) |
| Pro Unit/DocCode | 1212C14 | CA12 B.B.Compr. - Static Calculation |
| Pro Unit/DocCode | 1212C16 | CA12 B.B.Compr. - Piling Drwgs |
| Pro Unit/DocCode | 1212C21 | CA12 B.B.Compr. - Drwgs Foundation |
| Pro Unit/DocCode | 1300C01 | CA13 General - Layout Drwgs / Loads (IFD) |
| Pro Unit/DocCode | 1300C11 | CA13 General - General Drwgs & Documents |
| Pro Unit/DocCode | 1301C01 | CA13 Reactor Str. - Layout Drwgs/ Loads (IFD) |
| Pro Unit/DocCode | 1301C13 | CA13 Reactor Str. - Civil/Architect Layout Drwgs |
| Pro Unit/DocCode | 1301C14 | CA13 Reactor Str. - Static Calculation |
| Pro Unit/DocCode | 1301C16 | CA13 Reactor Str. - Piling Drwgs |
| Pro Unit/DocCode | 1301C21 | CA13 Reactor Str. - Drwgs Found./Base Plate |
| Pro Unit/DocCode | 1301C32 | CA13 Reactor Str. - Drwgs Concrete Str. |
| Pro Unit/DocCode | 1302C01 | CA13 Teal Bldg. - Layout Drwgs/ Loads (IFD) |
| Pro Unit/DocCode | 1302C13 | CA13 Teal Bldg. - Civil/Architect Layout Drwgs |
| Pro Unit/DocCode | 1302C14 | CA13 Teal Bldg. - Static Calculation |
| Pro Unit/DocCode | 1302C15 | CA13 Teal Bldg. - Fire Safety Survey Report |
| Pro Unit/DocCode | 1302C16 | CA13 Teal Bldg. - Piling Drwgs |
| Pro Unit/DocCode | 1302C21 | CA13 Teal Bldg. - Drwgs Found. / Base Plate |
| Pro Unit/DocCode | 1302C22 | CA13 Teal Bldg. - Drwgs Ground Level |
| Pro Unit/DocCode | 1302C41 | CA13 Teal Bldg. - Architetcural Detail Drwgs |
| Pro Unit/DocCode | 1302H21 | CA13 Teal Bldg. - Loads/Openings HVAC Systems |
| Pro Unit/DocCode | 1302H22 | CA13 Teal Bldg. - Calculations/Flow Diagrams HVAC Systems |
| Pro Unit/DocCode | 1302H23 | CA13 Teal Bldg. - HVAC Layout Drwgs AFC |
| Pro Unit/DocCode | 1302N51 | CA13 Teal Bldg. - Structural Steel Drwgs |
| Pro Unit/DocCode | 1304C01 | CA13 Conn.Teal S. - Layout Drwgs/ Loads (IFD) |
| Pro Unit/DocCode | 1304C13 | CA13 Conn.Teal S. - Civil/Architect Layout Drwgs |
| Pro Unit/DocCode | 1304C14 | CA13 Conn.Teal S. - Static Calculation |
| Pro Unit/DocCode | 1304C16 | CA13 Conn.Teal S. - Piling Drwgs |
| Pro Unit/DocCode | 1304C21 | CA13 Conn.Teal S. - Drwgs Found./Base Plate |
| Pro Unit/DocCode | 1304C53 | CA13 Conn.Teal S. - Precast Formw/Reinf. Drwgs |
| Pro Unit/DocCode | 1305C01 | CA13 Agitator R.U. - Layout Drwgs/ Loads (IFD) |
| Pro Unit/DocCode | 1305C13 | CA13 Agitator R.U. - Civil/Architec Layout Drwgs |
| Pro Unit/DocCode | 1305C14 | CA13 Agitator R.U. - Static Calculation |
| Pro Unit/DocCode | 1305C16 | CA13 Agitator R.U. - Piling Drwgs |
| Pro Unit/DocCode | 1305C21 | CA13 Agitator R.U. - Drwgs Found. / Base Plate |
| Pro Unit/DocCode | 1306C01 | CA13 Catalyst Bldg - Layout Drwgs/ Loads (IFD) |
| Pro Unit/DocCode | 1306C13 | CA13 Catalyst Bldg - Civil/Architec Layout Drwgs |
| Pro Unit/DocCode | 1306C14 | CA13 Catalyst Bldg - Static Calculation |
| Pro Unit/DocCode | 1306C15 | CA13 Catalyst Bldg. - Fire Safety Survey Report |
| Pro Unit/DocCode | 1306C16 | CA13 Catalyst Bldg - Piling Drwgs |
| Pro Unit/DocCode | 1306C21 | CA13 Catalyst Bldg - Drwgs Found. / Base Plate |
| Pro Unit/DocCode | 1306C22 | CA13 Catalyst Bldg - Drwgs Ground Level |
| Pro Unit/DocCode | 1306C23 | CA13 Catalyst Bldg - Drwgs 1st Level |
| Pro Unit/DocCode | 1306C24 | CA13 Catalyst Bldg - Drwgs 2nd Level |
| Pro Unit/DocCode | 1306C25 | CA13 Catalyst Bldg - Drwgs 3rd Level |
| Pro Unit/DocCode | 1306C41 | CA13 Catalyst Bldg - Architectural Detail Drwgs |
| Pro Unit/DocCode | 1306H21 | CA13 Catalyst Bldg. - Loads/Openings HVAC Systems |
| Pro Unit/DocCode | 1306H22 | CA13 Catalyst Bldg - Calculations/Flow Diagrams HVAC Systems |
| Pro Unit/DocCode | 1306H23 | CA13 Catalyst Bldg - HVAC Layout Drwgs AFC |
| Pro Unit/DocCode | 1306N51 | CA13 Catalyst Bldg - Structural Steel Drwgs |
| Pro Unit/DocCode | 1310C01 | CA13 Other Ground Eq - Layout Drwgs/Loads (IFD) |
| Pro Unit/DocCode | 1310C14 | CA13 Other Ground Eq - Static Calculation |
| Pro Unit/DocCode | 1310C21 | CA13 Other Ground Eq - Drwgs Foundation |
| Pro Unit/DocCode | 1311C01 | CA13 R.G.Compr. - Layout Drwgs/ Loads (IFD) |
| Pro Unit/DocCode | 1311C14 | CA13 R.G.Compr. - Static Calculation |
| Pro Unit/DocCode | 1311C16 | CA13 R.G.Compr. - Piling Drwgs |
| Pro Unit/DocCode | 1311C21 | CA13 R.G.Compr. - Drwgs Foundation |
| Pro Unit/DocCode | 1400C01 | CA14 General - Layout Drwgs / Loads (IFD) |
| Pro Unit/DocCode | 1400C11 | CA14 General - General Drwgs & Documents |
| Pro Unit/DocCode | 1401C01 | CA14 Flare Pck. - Layout Drwgs / Loads (IFD) |
| Pro Unit/DocCode | 1401C13 | CA14 Flare Pck. - Civil/Architect Layout Drwgs |
| Pro Unit/DocCode | 1401C14 | CA14 Flare Pck. - Static Calculation |
| Pro Unit/DocCode | 1401C16 | CA14 Flare Pck. - Static Calculation |
| Pro Unit/DocCode | 1401C21 | CA14 Flare Pck. - Drwgs Found./Base Plate |
| Pro Unit/DocCode | 1420C01 | CA11 Flare KO - Layout Drwgs / Loads (IFD) |
| Pro Unit/DocCode | 1420C13 | CA11 Flare KO - Civil/Architect Layout Drwgs |
| Pro Unit/DocCode | 1420C14 | CA11 Flare KO - Static Calculation |
| Pro Unit/DocCode | 1420C16 | CA11 Flare KO - Piling Drwgs |
| Pro Unit/DocCode | 1420C21 | CA11 Flare KO - Drwgs Found./Base Plate |
| Pro Unit/DocCode | 1500C11 | CA15 General - General Drwgs & Documents |
| Pro Unit/DocCode | 1510C01 | CA15 SanitLiftStat - Layout Drwgs/ Loads (IFD) |
| Pro Unit/DocCode | 1510C13 | CA15 SanitLiftStat - Civil/Architect Layout Drwg |
| Pro Unit/DocCode | 1510C14 | CA15 SanitLiftStat - Static Calculation |
| Pro Unit/DocCode | 1511C01 | CA15 Air Buffer V - Layout Drwgs/ Loads (IFD) |
| Pro Unit/DocCode | 1511C14 | CA15 Air Buffer V - Static Calculation |
| Pro Unit/DocCode | 1511C16 | CA15 Air Buffer V - Piling Drwgs |
| Pro Unit/DocCode | 1511C21 | CA15 Air Buffer V - Drwgs Foundation |
| Pro Unit/DocCode | 1600C11 | CA16 General - General Drwgs & Documents |
| Pro Unit/DocCode | 1601C01 | CA16 Substation - Layout Drwgs/ Loads (IFD) |
| Pro Unit/DocCode | 1601C13 | CA16 Substation - Civil/Architec Layout Drwgs |
| Pro Unit/DocCode | 1601C14 | CA16 Substation - Static Calculation |
| Pro Unit/DocCode | 1601C15 | CA16 Substation - Fire Safety Survey Report |
| Pro Unit/DocCode | 1601C16 | CA16 Substation - Piling Drwgs |
| Pro Unit/DocCode | 1601C21 | CA16 Substation - Drwgs Found. / Base Plate |
| Pro Unit/DocCode | 1601C22 | CA16 Substation - Drwgs Ground Level |
| Pro Unit/DocCode | 1601C23 | CA16 Substation - Drwgs 1st Level |
| Pro Unit/DocCode | 1601C24 | CA16 Substation - Drwgs 2nd Level |
| Pro Unit/DocCode | 1601C31 | CA16 Substation - Precast Layout Drwgs |
| Pro Unit/DocCode | 1601C41 | CA16 Substation - Architectural Detail Drwgs |
| Pro Unit/DocCode | 1601C42 | CA16 Substation - False Floor Drwgs |
| Pro Unit/DocCode | 1601C53 | CA16 Substation - Precast Formw/Reinf. Drwgs +0,00m |
| Pro Unit/DocCode | 1601C54 | CA16 Substation - Precast Formw/Reinf. Drwgs +3,00m |
| Pro Unit/DocCode | 1601C55 | CA16 Substation - Precast Formw/Reinf. Drwgs +9,20m |
| Pro Unit/DocCode | 1601H21 | CA16 Substation - Loads/Openings HVAC Systems |
| Pro Unit/DocCode | 1601H22 | CA16 Substation - Calculations/Flow Diagrams HVAC Systems |
| Pro Unit/DocCode | 1601H23 | CA16 Substation - HVAC Layout Drwgs AFC |
| Pro Unit/DocCode | 1601N51 | CA16 Substation - Structural Steel Drwgs |
| Pro Unit/DocCode | 1700C01 | CA17 General - Layout Drwgs / Loads (IFD) |
| Pro Unit/DocCode | 1701C01 | CA17 Extr Bldg. - Layout Drwgs/ Loads (IFD) |
| Pro Unit/DocCode | 1701C13 | CA17 Extr Bldg. - Civil/Architec Layout Drwgs |
| Pro Unit/DocCode | 1701C14 | CA17 Extr Bldg. - Static Calculation |
| Pro Unit/DocCode | 1701C15 | CA17 Extr Bldg. - Fire Safety Survey Report |
| Pro Unit/DocCode | 1701C16 | CA17 Extr Bldg. - Piling Drwgs |
| Pro Unit/DocCode | 1701C21 | CA17 Extr Bldg. - Drwgs Found. / Base Plate |
| Pro Unit/DocCode | 1701C22 | CA17 Extr Bldg. - Drwgs Ground Level |
| Pro Unit/DocCode | 1701C23 | CA17 Extr Bldg. - Drwgs Ceiling (+12m) 1st Level |
| Pro Unit/DocCode | 1701C24 | CA17 Extr Bldg. - Drwgs Ceiling (+18m) 2nd Level |
| Pro Unit/DocCode | 1701C25 | CA17 Extr Bldg. - Drwgs Ceiling (+24m) 3rd Level |
| Pro Unit/DocCode | 1701C26 | CA17 Extr Bldg. - Drwgs Ceiling (+30m) 4th Level |
| Pro Unit/DocCode | 1701C27 | CA17 Extr Bldg. - Drwgs Ceiling (+36m) 5th Level |
| Pro Unit/DocCode | 1701C28 | CA17 Extr Bldg. - Drwgs (abv. 36m) 6th Level |
| Pro Unit/DocCode | 1701C31 | CA17 Extr Bldg. - Precast Drwgs |
| Pro Unit/DocCode | 1701C41 | CA17 Extr Bldg. - Architectural Detail Drwgs |
| Pro Unit/DocCode | 1701C54 | CA17 Extr Bldg. - Precast Drwgs Beams/Stairs <12m 1st Level |
| Pro Unit/DocCode | 1701C55 | CA17 Extr Bldg. - Precast Drwgs Stairs <18m 2nd Level |
| Pro Unit/DocCode | 1701C56 | CA17 Extr Bldg. - Precast Drwgs Stairs <24m 3rd Level |
| Pro Unit/DocCode | 1701C57 | CA17 Extr Bldg. - Precast Drwgs Stairs <30m 4th Level |
| Pro Unit/DocCode | 1701C58 | CA17 Extr Bldg. - Precast Drwgs Stairs <36m 5th Level |
| Pro Unit/DocCode | 1701C96 | CA17 Extr Bldg. - Paving Drwgs |
| Pro Unit/DocCode | 1701H21 | CA17 Extr Bldg. - Loads/Openings HVAC Systems |
| Pro Unit/DocCode | 1701H22 | CA17 Extr Bldg.- Calculations/Flow Diagrams HVAC Systems |
| Pro Unit/DocCode | 1701H23 | CA17 Extr Bldg. - HVAC Layout Drwgs AFC |
| Pro Unit/DocCode | 1701N51 | CA17 Extr Bldg. - Structural Steel Drwgs |
| Pro Unit/DocCode | 1707C01 | CA17 Conn.PR CA12 - Layout Drwgs/ Loads (IFD) |
| Pro Unit/DocCode | 1707C13 | CA17 Conn.PR CA12 - Civil/Architec Layout Drwgs |
| Pro Unit/DocCode | 1707C14 | CA17 Conn.PR CA12 - Static Calculation |
| Pro Unit/DocCode | 1707C16 | CA17 Conn.PR CA12 - Piling Drwgs |
| Pro Unit/DocCode | 1707C21 | CA17 Conn.PR CA12 - Drwgs Found. / Base Plate |
| Pro Unit/DocCode | 1707C31 | CA17 Conn.PR CA12 - Precast Drwgs |
| Pro Unit/DocCode | 1708C01 | CA17 Conn.PR CA13 - Layout Drwgs/ Loads (IFD) |
| Pro Unit/DocCode | 1708C13 | CA17 Conn.PR CA13 - Civil/Architec Layout Drwgs |
| Pro Unit/DocCode | 1708C14 | CA17 Conn.PR CA13 - Static Calculation |
| Pro Unit/DocCode | 1708C16 | CA17 Conn.PR CA13 - Piling Drwgs |
| Pro Unit/DocCode | 1708C21 | CA17 Conn.PR CA13 - Drwgs Found. / Base Plate |
| Pro Unit/DocCode | 1708C31 | CA17 Conn.PR CA13 - Precast Drwgs |
| Pro Unit/DocCode | 1711C01 | CA17 Extruder Eq. - Layout Drwgs/ Loads (IFD) |
| Pro Unit/DocCode | 1711C14 | CA17 Extruder Eq - Static Calculation |
| Pro Unit/DocCode | 1711C21 | CA17 Extruder Eq. - Drwgs Found. / Base Plate |
| Pro Unit/DocCode | 210 | Unit 210/220 |
| Pro Unit/DocCode | 211 | Unit 211/221 |
| Pro Unit/DocCode | 212 | Unit 212/222 |
| Pro Unit/DocCode | 213 | Unit 213/223 |
| Pro Unit/DocCode | 214 | Unit 214/224 |
| Pro Unit/DocCode | 215 | Unit 215 |
| Pro Unit/DocCode | 218 | Unit 218 |
| Pro Unit/DocCode | 3100C01 | CA31 General - Layout Drwgs / Loads (IFD) |
| Pro Unit/DocCode | 3100C11 | CA31 General - General Drwgs & Documents |
| Pro Unit/DocCode | 3100C15 | CA31 General - Fire Safety Survey Report |
| Pro Unit/DocCode | 3101C01 | CA31 Silo Str - Layout Drwgs/ Loads (IFD) |
| Pro Unit/DocCode | 3101C13 | CA31 Silo Str. - Civil/Architec Layout Drwgs |
| Pro Unit/DocCode | 3101C14 | CA31 Silo Str. - Static Calculation |
| Pro Unit/DocCode | 3101C16 | CA31 Silo Str. - Piling Drwgs |
| Pro Unit/DocCode | 3101C21 | CA31 Silo Str. - Drwgs Found. / Base Plate |
| Pro Unit/DocCode | 3101C22 | CA31 Silo Str. - Drwgs Ground Level |
| Pro Unit/DocCode | 3101C23 | CA31 Silo Str. - Drwgs 1st Level |
| Pro Unit/DocCode | 3101C24 | CA31 Silo Str. - Drwgs 2nd Level |
| Pro Unit/DocCode | 3101C25 | CA31 Silo Str. - Drwgs 3rd Level |
| Pro Unit/DocCode | 3101C31 | CA31 Silo Str. - Precast Layout Drwgs |
| Pro Unit/DocCode | 3101C41 | CA31 Silo Str. - Architectural Detail Drwgs |
| Pro Unit/DocCode | 3101C55 | CA31 Silo Str. - Precast Detail Formw/Reinf. Drwgs <23,50m |
| Pro Unit/DocCode | 3101C61 | CA31 Silo Str. - Structural Steel |
| Pro Unit/DocCode | 3101C96 | CA31 Silo Str. - Paving Drwgs AFC |
| Pro Unit/DocCode | 3101H21 | CA31 Silo Str. - Loads/Openings HVAC Systems |
| Pro Unit/DocCode | 3101H22 | CA31 Silo Str. - Calculations/Flow Diagrams HVAC Systems |
| Pro Unit/DocCode | 3101H23 | CA31 Silo Str. - HVAC Layout Drwgs AFC |
| Pro Unit/DocCode | 3102C01 | CA31 Warehouse - Layout Drwgs/ Loads (IFD) |
| Pro Unit/DocCode | 3102C13 | CA31 Warehouse - Civil/Architec Layout Drwgs |
| Pro Unit/DocCode | 3102C14 | CA31 Warehouse - Static Calculation |
| Pro Unit/DocCode | 3102C16 | CA31 Warehouse - Piling Drwgs |
| Pro Unit/DocCode | 3102C21 | CA31 Warehouse - Drwgs Found. / Base Plate |
| Pro Unit/DocCode | 3102C22 | CA31 Warehouse - Drwgs Ground Level |
| Pro Unit/DocCode | 3102C31 | CA31 Warehouse - Precast Layout Drwgs |
| Pro Unit/DocCode | 3102C41 | CA31 Warehouse - Architectural Detail Drwgs |
| Pro Unit/DocCode | 3102C53 | CA31 Warehouse - Precast Formw/Reinf. Drwgs |
| Pro Unit/DocCode | 3102C96 | CA31 Warehouse - Paving Drwgs AFC |
| Pro Unit/DocCode | 3102H21 | CA31 Warehouse - Loads/Openings HVAC Systems |
| Pro Unit/DocCode | 3102H22 | CA31 Warehouse - Calculations/Flow Diagrams HVAC Systems |
| Pro Unit/DocCode | 3102H23 | CA31 Warehouse - HVAC Layout Drwgs AFC |
| Pro Unit/DocCode | 3103C01 | CA31 Warehouse - Layout Drwgs/ Loads (IFD) |
| Pro Unit/DocCode | 3103C13 | CA31 Service Area - Civil/Architec Layout Drwgs |
| Pro Unit/DocCode | 3103C14 | CA31 Service Area - Static Calculation |
| Pro Unit/DocCode | 3103C16 | CA31 Service Area - Piling Drwgs |
| Pro Unit/DocCode | 3103C21 | CA31 Service Area - Drwgs Found. / Base Plate |
| Pro Unit/DocCode | 3103C22 | CA31 Service Area - Drwgs Ground Level |
| Pro Unit/DocCode | 3103C23 | CA31 Service Area - Drwgs 1st Level |
| Pro Unit/DocCode | 3103C31 | CA31 Service Area - Precast Layout Drwgs |
| Pro Unit/DocCode | 3103C41 | CA31 Service Area - Architectural Detail Drwgs |
| Pro Unit/DocCode | 3103C42 | CA31 Service Area - False Floor Drwgs AFC |
| Pro Unit/DocCode | 3103C53 | CA31 Service Area - Precast Detail Formw/Reinf. Drwgs <6,90m |
| Pro Unit/DocCode | 3103C54 | CA31 Service Area - Precast Detail Formw/Reinf. Drwgs <13,50m |
| Pro Unit/DocCode | 3103C61 | CA31 Service Area - Structural Steel |
| Pro Unit/DocCode | 3103C96 | CA31 Service Area - Paving Drwgs AFC |
| Pro Unit/DocCode | 3103H21 | CA31 Service Area - Loads/Openings HVAC Systems |
| Pro Unit/DocCode | 3103H22 | CA31 Service Area - Calculations/Flow Diagrams HVAC Systems |
| Pro Unit/DocCode | 3103H23 | CA31 Service Area - HVAC Layout Drwgs AFC |
| Pro Unit/DocCode | 3104C01 | CA31 Blower Section - Layout Drwgs/ Loads (IFD) |
| Pro Unit/DocCode | 3104C13 | CA31 Blower Sectio - Civil/Architec Layout Drwgs |
| Pro Unit/DocCode | 3104C14 | CA31 Blower Section - Static Calculation |
| Pro Unit/DocCode | 3104C16 | CA31 Blower Section - Piling Drwgs |
| Pro Unit/DocCode | 3104C21 | CA31 Blower Section - Drwgs Found. / Base Plate |
| Pro Unit/DocCode | 3104C22 | CA31 Blower Section - Drwgs Ground Level |
| Pro Unit/DocCode | 3104C23 | CA31 Blower Section - Drwgs 1st Level |
| Pro Unit/DocCode | 3104C24 | CA31 Blower Section - Drwgs 2nd Level |
| Pro Unit/DocCode | 3104C31 | CA31 Blower Section - Precast Layout Drwgs |
| Pro Unit/DocCode | 3104C41 | CA31 Blower Section - Architectural Detail Drwgs |
| Pro Unit/DocCode | 3104C53 | CA31 Blower Section - Precast Detail Formw/Reinf. Drwgs <7,20m |
| Pro Unit/DocCode | 3104C54 | CA31 Blower Section - Precast Detail Formw/Reinf. Drwgs <13,80m |
| Pro Unit/DocCode | 3104C61 | CA31 Blower Section - Structural Steel |
| Pro Unit/DocCode | 3104C96 | CA31 Blower Section - Paving Drwgs AFC |
| Pro Unit/DocCode | 3104H21 | CA31 Blower Section - Loads/Openings HVAC Systems |
| Pro Unit/DocCode | 3104H22 | CA31 Blower Section - Calculations/Flow Diagrams HVAC Systems |
| Pro Unit/DocCode | 3104H23 | CA31 Blower Section - HVAC Layout Drwgs AFC |
| Pro Unit/DocCode | 3105C01 | CA31 Silo Staircase - Layout Drwgs/ Loads (IFD) |
| Pro Unit/DocCode | 3105C14 | CA31 Silo Staircase - Static Calculation |
| Pro Unit/DocCode | 3105C21 | CA31 Silo Staircase - Drwgs Found. / Base Plate |
| Pro Unit/DocCode | 3105C61 | CA31 Silo Staircase - Structural Steel |
| Pro Unit/DocCode | 3111C01 | CA31 Blower Found. - Layout Drwgs/ Loads (IFD) |
| Pro Unit/DocCode | 400 | All Units / Package Units |
| Pro Unit/DocCode | 5100C01 | CA51 PR5101 - Layout Drwgs/ Loads (IFD) |
| Pro Unit/DocCode | 5101C14 | CA51 PR5101 - Static Calculation |
| Pro Unit/DocCode | 5101C16 | CA51 PR5101 - Piling Drwgs |
| Pro Unit/DocCode | 5101C21 | CA51 PR5101 - Drwgs Found. / Base Plate |
| Pro Unit/DocCode | 5101C31 | CA51 PR5101 - Precast Layout Drwgs |
| Pro Unit/DocCode | 5101C53 | CA51 PR5101 - Precast Detail Formw/Reinf. Drwgs |
| Pro Unit/DocCode | 5102C14 | CA51 PR5102 - Static Calculation |
| Pro Unit/DocCode | 5102C16 | CA51 PR5102 - Piling Drwgs |
| Pro Unit/DocCode | 5102C21 | CA51 PR5102 - Drwgs Found. / Base Plate |
| Pro Unit/DocCode | 5102C31 | CA51 PR5102 - Precast Layout Drwgs |
| Pro Unit/DocCode | 5102C53 | CA51 PR5102 - Precast Detail Formw/Reinf. Drwgs |
| Pro Unit/DocCode | 5103C14 | CA51 PR5103 - Static Calculation |
| Pro Unit/DocCode | 5103C16 | CA51 PR5103 - Piling Drwgs |
| Pro Unit/DocCode | 5103C21 | CA51 PR5103 - Drwgs Found. / Base Plate |
| Pro Unit/DocCode | 5103C31 | CA51 PR5103 - Precast Layout Drwgs |
| Pro Unit/DocCode | 5103C53 | CA51 PR5103 - Precast Detail Formw/Reinf. Drwgs |
| Pro Unit/DocCode | 5104C14 | CA51 PR5104 - Static Calculation |
| Pro Unit/DocCode | 5104C16 | CA51 PR5104 - Piling Drwgs |
| Pro Unit/DocCode | 5104C21 | CA51 PR5104 - Drwgs Found. / Base Plate |
| Pro Unit/DocCode | 5104C31 | CA51 PR5104 - Precast Layout Drwgs |
| Pro Unit/DocCode | 5104C53 | CA51 PR5104 - Precast Detail Formw/Reinf. Drwgs |
| Pro Unit/DocCode | 5200C01 | CA52 PR5201 - Layout Drwgs/ Loads (IFD) |
| Pro Unit/DocCode | 5201C14 | CA52 PR5201 - Static Calculation |
| Pro Unit/DocCode | 5201C16 | CA52 PR5201 - Piling Drwgs |
| Pro Unit/DocCode | 5201C21 | CA52 PR5201 - Drwgs Found. / Base Plate |
| Pro Unit/DocCode | 5201C31 | CA52 PR5201 - Precast Layout Drwgs |
| Pro Unit/DocCode | 5201C53 | CA52 PR5201 - Precast Detail Formw/Reinf. Drwgs |
| Pro Unit/DocCode | 5300C01 | CA53 PR5301 - Layout Drwgs/ Loads (IFD) |
| Pro Unit/DocCode | 5301C13 | CA53 PR5301 - Civil/Architec Layout Drwgs |
| Pro Unit/DocCode | 5301C14 | CA53 PR5301 - Static Calculation |
| Pro Unit/DocCode | 5301C16 | CA53 PR5301 - Piling Drwgs |
| Pro Unit/DocCode | 5301C21 | CA53 PR5301 - Drwgs Found. / Base Plate |
| Pro Unit/DocCode | 5301C31 | CA53 PR5301 - Precast Layout Drwgs |
| Pro Unit/DocCode | 5301C53 | CA53 PR5301 - Precast Detail Formw/Reinf. Drwgs |
| Pro Unit/DocCode | 5400C01 | CA54 PR5401 - Layout Drwgs/ Loads (IFD) |
| Pro Unit/DocCode | 5401C13 | CA54 PR5401 - Civil/Architec Layout Drwgs |
| Pro Unit/DocCode | 5401C14 | CA54 PR5401 - Static Calculation |
| Pro Unit/DocCode | 5401C16 | CA54 PR5401 - Piling Drwgs |
| Pro Unit/DocCode | 5401C21 | CA54 PR5401 - Drwgs Found. / Base Plate |
| Pro Unit/DocCode | 5402C13 | CA54 PR5402 - Civil/Architec Layout Drwgs |
| Pro Unit/DocCode | 5402C14 | CA54 PR5402 - Static Calculation |
| Pro Unit/DocCode | 5402C16 | CA54 PR5402 - Piling Drwgs |
| Pro Unit/DocCode | 5402C21 | CA54 PR5402 - Drwgs Found. / Base Plate |
| Pro Unit/DocCode | 5500C01 | CA55 PR5501 - Layout Drwgs/ Loads (IFD) |
| Pro Unit/DocCode | 5501C13 | CA55 PR5501 - Civil/Architec Layout Drwgs |
| Pro Unit/DocCode | 5501C14 | CA55 PR5501 - Static Calculation |
| Pro Unit/DocCode | 5501C16 | CA55 PR5501 - Piling Drwgs |
| Pro Unit/DocCode | 5501C21 | CA55 PR5501 - Drwgs Found. / Base Plate |
| Pro Unit/DocCode | 5502C13 | CA55 PR5502 - Civil/Architec Layout Drwgs |
| Pro Unit/DocCode | 5502C14 | CA55 PR5502 - Static Calculation |
| Pro Unit/DocCode | 5502C16 | CA55 PR5502 - Piling Drwgs |
| Pro Unit/DocCode | 5502C21 | CA55 PR5502 - Drwgs Found. / Base Plate |
| Pro Unit/DocCode | 5503C13 | CA55 PR5503 - Civil/Architec Layout Drwgs |
| Pro Unit/DocCode | 5503C14 | CA55 PR5503 - Static Calculation |
| Pro Unit/DocCode | 5503C16 | CA55 PR5503 - Piling Drwgs |
| Pro Unit/DocCode | 5503C21 | CA55 PR5503 - Drwgs Found. / Base Plate |
| Pro Unit/DocCode | 5600C01 | CA56 PR5601 - Layout Drwgs/ Loads (IFD) |
| Pro Unit/DocCode | 5601C13 | CA56 PR5601 - Civil/Architec Layout Drwgs |
| Pro Unit/DocCode | 5601C14 | CA56 PR5601 - Static Calculation |
| Pro Unit/DocCode | 5601C16 | CA56 PR5601 - Piling Drwgs |
| Pro Unit/DocCode | 5601C21 | CA56 PR5601 - Drwgs Found. / Base Plate |
| Pro Unit/DocCode | 90 | Activities for Product Handling |
| Pro Unit/DocCode | 9000C01 | CA90 (UP) Overall - Civil Layout Drwgs and Found. Loads (IFD) |
| Pro Unit/DocCode | 9000C12 | CA90 (UP) Overall - Civil Design Drwgs |
| Pro Unit/DocCode | 9001C14 | CA90 (UP) Oily W.W.Sewer Sys. - Calculations |
| Pro Unit/DocCode | 9001C90 | CA90 (UP) Oily W.W.Sewer Sys. - Drwgs |
| Pro Unit/DocCode | 9003C14 | CA90 (Down) Sanitary W.W.Sys. - Calculations |
| Pro Unit/DocCode | 9003C90 | CA90 (Down) Sanitary W.W.Sys. - Drwgs |
| Pro Unit/DocCode | 9004C14 | CA90 (UP) Medium Press.Firew.Sys. - Calculations |
| Pro Unit/DocCode | 9004C91 | CA90 (UP) Medium Press.Firew.Sys. - Drwgs |
| Pro Unit/DocCode | 9005C14 | CA90 (UP) High Press.Firew.Sys. - Calculations |
| Pro Unit/DocCode | 9005C91 | CA90 (UP) High Press.Firew.Sys. - Drwgs |
| Pro Unit/DocCode | 9007C14 | CA90 (UP) Potable Water Sys. - Calculations |
| Pro Unit/DocCode | 9007C92 | CA90 (UP) Potable Water Sys. - Drwgs |
| Pro Unit/DocCode | 9008C14 | CA90 (UP) Service Water Sys. - Calculations |
| Pro Unit/DocCode | 9008C92 | CA90 (UP) Service Water Sys. - Drwgs |
| Pro Unit/DocCode | 9030C01 | CA90 (Down) Overall - Civil Layout Drwgs and Found. Loads (IFD) |
| Pro Unit/DocCode | 9030C11 | CA90 (Down) Oily W.W.Sewer Sys. - Gen.Drwgs & Do |
| Pro Unit/DocCode | 9031C14 | CA90 (Down) Oily W.W.Sewer Sys. - Calculations |
| Pro Unit/DocCode | 9031C90 | CA90 (Down) Oily W.W.Sewer Sys. - Drwgs |
| Pro Unit/DocCode | 9033C14 | CA90 (UP) Sanitary W.W.Sys. - Calculations |
| Pro Unit/DocCode | 9033C90 | CA90 (UP) Sanitary W.W.Sys. - Drwgs |
| Pro Unit/DocCode | 9034C14 | CA90 (Down) Medium Press.Firew.Sys. - Calculatio |
| Pro Unit/DocCode | 9034C91 | CA90 (Down) Medium Press.Firew.Sys. - Drwgs |
| Pro Unit/DocCode | 9037C14 | CA90 (Down) Potable Water Sys. - Calculations |
| Pro Unit/DocCode | 9037C92 | CA90 (Down) Potable Water Sys. - Drwgs |
| Pro Unit/DocCode | 9038C14 | CA90 (Down) Service Water Sys. - Calculations |
| Pro Unit/DocCode | 9038C92 | CA90 (Down) Service Water Sys. - Drwgs |
| Pro Unit/DocCode | 91 | Activities for PP Process Plant |
| Pro Unit/DocCode | 9531C01 | CA31 Asphalt Paving Layout Drwgs / Loads (IFD) |
| Pro Unit/DocCode | 9531C14 | CA31 Calculations Asphalt Paving |
| Pro Unit/DocCode | 9531C95 | CA31 Asphalt Paving Drwgs |
| Pro Unit/DocCode | 9600C01 | CA90 (UP) Overall - Civil Layout Drwgs/Loads IFD |
| Pro Unit/DocCode | 9600C14 | Upstream Overall - Calculations Concrete Paving |
| Pro Unit/DocCode | 9600C16 | Upstream Overall - Piling Design |
| Pro Unit/DocCode | 9600C96 | Upstream Overall - Concrete Paving Drawgings |
| Pro Unit/DocCode | 9610C96 | CA10 Paving Drwgs |
| Pro Unit/DocCode | 9611C96 | CA11 Paving Drwgs |
| Pro Unit/DocCode | 9612C96 | CA12 Paving Drwgs |
| Pro Unit/DocCode | 9613C96 | CA13 Paving Drwgs |
| Pro Unit/DocCode | 9614C96 | CA14 Paving Drwgs |
| Pro Unit/DocCode | 9615C96 | CA15 Paving Drwgs |
| Pro Unit/DocCode | 9616C96 | CA16 Paving Drwgs |
| Pro Unit/DocCode | 9617C96 | CA17 Paving Drwgs (outside Extr. Bldg.) |
| Pro Unit/DocCode | 9631C01 | CA90 Paving (down) - Layout Drwgs / Loads (IFD) |
| Pro Unit/DocCode | 9631C13 | CA90 Paving (down) - Civil Layout Drwgs Paving |
| Russia Construction Area | 00 | Строительство - Общее |
| Russia Construction Area | 0C | Сроки строительства по дисциплинам |
| Russia Construction Area | 31 | CA31 - Здание хранения/упаковки и отгрузки |
| Russia WBS Discipline (Russia) | 0 | Дисциплины - Общее |
| Russia WBS Discipline (Russia) | E | Электрооборудование |
| Russia WBS Discipline (Russia) | R | Трубопроводы |
| Russia WBS Objects | 0000 | Общее - все CA |
| Russia WBS Objects | 3110 | Конструкция силоса - CA31 |
| Russia WBS Phase | E | Engineering |
| Russia WBS Phase | P | Procurement |
| Russia WBS Phase | X | Строительство |
| Type of Work | A00 | Mechanical Subcontract |
| Type of Work | A00B | Eng Stat Eqpt - General |
| Type of Work | A01 | Drums / Small Pressure Vessels |
| Type of Work | A02A | Large Drums |
| Type of Work | A02B | Polymer Water Basket |
| Type of Work | A02C | Instrument Air Vessels |
| Type of Work | A02D | Vessels - Central Chiller Unit |
| Type of Work | A03 | Catalyst Drum Roller |
| Type of Work | A04 | Reactor Overhead Separators |
| Type of Work | A04A | Reactor Overhead Condensors |
| Type of Work | A05 | Offgas Cyclone & Receiver |
| Type of Work | A06 | Start-up Gas Heaters |
| Type of Work | A06A | Electrical Heater |
| Type of Work | A07 | Reactor Fines Eductor |
| Type of Work | A08 | Purge Columns Vent / Gas Expans. Bag Filter |
| Type of Work | A11 | Unloading Arms |
| Type of Work | A12 | Overhead Cranes >32t |
| Type of Work | A13 | Scales |
| Type of Work | A16 | Offgas Compressor Filters |
| Type of Work | A17 | Teal Stripping Column Internal |
| Type of Work | A18 | Flare Package |
| Type of Work | A25 | Safety Showers |
| Type of Work | AA | Project Management |
| Type of Work | ALL1 | Reactors w. Agitators |
| Type of Work | ALL2 | Purge Columns |
| Type of Work | ALL4 | Silos & Blenders |
| Type of Work | C01 | Piling Subcontract |
| Type of Work | C02 | Civil Subcontract General |
| Type of Work | C02A | Civil Subcontract (Group 1 - CNCEC/ENKA) |
| Type of Work | C02B | Civil Subcontract (Group 2) |
| Type of Work | D01 | General Cargo Subcontract |
| Type of Work | E00 | E&I Subcontract |
| Type of Work | E01A | MV-SWG / MCC |
| Type of Work | E01B | LV-SWG / MCC / Freq.Conv. / Softstarter / Capacitators / Power Controller |
| Type of Work | E02 | Transformer |
| Type of Work | E03 | Distribution/Lighting Panels (In-/Outdoor) |
| Type of Work | E04 | Reactor Gear Motors |
| Type of Work | E07 | UPS/DC-System |
| Type of Work | E09 | Lighting & Power Sockets (E+I SUB) |
| Type of Work | E11 | Earthing (E+I SUB) |
| Type of Work | E12 | Fire Detection System |
| Type of Work | E13 | CCTV / Communication System |
| Type of Work | E14 | Local Switches / Push Button Station EDG |
| Type of Work | E15A | Electrical MV Power Cable |
| Type of Work | E15B | Electrical LV Power Cable |
| Type of Work | E15C | Cable Glands & Connection Kits |
| Type of Work | E16 | Electrical Cable Tray Sys. |
| Type of Work | E17 | Aviation Lights |
| Type of Work | E19 | Electrical Heat Tracing System |
| Type of Work | E22 | Diesel Generator |
| Type of Work | H01 | HVAC Equipment |
| Type of Work | J01 | Ball Valves PDS |
| Type of Work | J01A | Ball Balves |
| Type of Work | J02 | Control Valves |
| Type of Work | J02A | PCV Valves |
| Type of Work | J02B | Knife Valves |
| Type of Work | J02C | Butterfly Valves on/off + Control |
| Type of Work | J02D | ON/OFF Plug Valves |
| Type of Work | J03 | Nuclear Level Measurement |
| Type of Work | J04A | Coriolis Mass Flowmeter |
| Type of Work | J04B | Vortex Flowmeter |
| Type of Work | J04C | Integral Orifice / Orifice / Venturi Tubes |
| Type of Work | J04E | Variable Area Flowmeter (Rotameter) |
| Type of Work | J04I | Ultrasonic Flowmeters |
| Type of Work | J05 | Machine Protection-/Conditiong. Monitoring Sys. |
| Type of Work | J06 | DCS / SIS |
| Type of Work | J06A | Power Supply Cabinets |
| Type of Work | J06B | Interface/Special Device Cabinets (E+I) |
| Type of Work | J06E | Junction Boxes |
| Type of Work | J06F | PLC Network |
| Type of Work | J07 | Analyser System |
| Type of Work | J07A | Sample Boards |
| Type of Work | J07B | Local Operation Panels / Hand Switches and Alarms |
| Type of Work | J07C | Local Indicator Panels |
| Type of Work | J09 | Instr.Cable Trays & Bulk Material |
| Type of Work | J12A | Radar Level Meas. Devices |
| Type of Work | J12B | Magnetic Level Gauges |
| Type of Work | J12D | Vibration Fork Level Switch |
| Type of Work | J13 | Diff.-, Pressure Transmitter (Flow/Level) |
| Type of Work | J13A | Pressure Gauges |
| Type of Work | J13B | Pressure Transmitter |
| Type of Work | J13C | Pressure Switches |
| Type of Work | J14 | Temp. Transmitter |
| Type of Work | J14A | Thermowell and Elements |
| Type of Work | J14B | Temperature Gauges |
| Type of Work | J15 | Winterization Enclosures |
| Type of Work | J17 | Instrument Cable (E+I SUB) |
| Type of Work | J18 | Weighing for Vessels |
| Type of Work | M01 | Extruder Package |
| Type of Work | M01A | PCW Cooler |
| Type of Work | M02 | Recycle Gas Compressors |
| Type of Work | M03 | Offgas Compressor Package |
| Type of Work | M04 | Gas Bleed Compressor Pack. (K-21801) |
| Type of Work | M05 | Reactor Quench Liquid Pumps |
| Type of Work | M06 | Reactor Tepid Water Pumps |
| Type of Work | M07 | Catalyst Feed Pumps |
| Type of Work | M08 | Teal & Donor Feed Pumps |
| Type of Work | M09 | Unloading Pumps |
| Type of Work | M10 | Catalyst/Co-Catalyst Waste Pumps |
| Type of Work | M11 | Reactor Agitator Gear Unit |
| Type of Work | M12 | Rotary Feeders |
| Type of Work | M14 | Submersible Pumps |
| Type of Work | M15 | Condensate / Service Water Pumps |
| Type of Work | M16 | Instrument Air Compressor |
| Type of Work | M17 | Central Chiller Unit |
| Type of Work | M18 | Pumps - Central Chiller Unit |
| Type of Work | N01 | Structural Steel Fabrication Subcontract |
| Type of Work | N012 | Structural Steel Erection Subcontract |
| Type of Work | N01A | Pipe Rack - SR5101 |
| Type of Work | N01B | Pipe Rack - SR5102 |
| Type of Work | N01C | Pipe Rack - SR5103 |
| Type of Work | N01D | Pipe Rack - SR5104 |
| Type of Work | N01E | Pipe Rack - SR5201 |
| Type of Work | N01F | Pipe Rack - SR5301 |
| Type of Work | N01G | Pipe Rack - SR5401 |
| Type of Work | N01H | Pipe Rack - SR5402 |
| Type of Work | N01I | Pipe Rack - SR5501 |
| Type of Work | N01J | Pipe Rack - SR5601 |
| Type of Work | N01L | Pipe Rack SR5502 |
| Type of Work | N01M | Pipe Rack SR5503 |
| Type of Work | N02" | SK3106 Supports CA31 |
| Type of Work | N02# | SK3105 Silo Staircase |
| Type of Work | N02$ | SK1306 Catalyst Bldg Line 2 |
| Type of Work | N02* | SK1104 Offgas Compressor Filter Section |
| Type of Work | N021 | SK1701 Extruder Structure 1st Floor |
| Type of Work | N022 | SK1701 Extruder Structure 2nd Floor |
| Type of Work | N023 | SK1701 Extruder Structure 3rd Floor |
| Type of Work | N024 | SK1701 Extruder Structure 4th Floor |
| Type of Work | N025 | SK1701 Extruder Structure 5th Floor |
| Type of Work | N02A | SK1105 Structures inside Compressor Bldg. |
| Type of Work | N02B | SK1601 Substation - Auxiliary/Platforms in-/outside |
| Type of Work | N02C | SK1401 Flare Knockout Drum Structure |
| Type of Work | N02D | SK1201 Reactor Structure |
| Type of Work | N02E | SK1204 Connection Str. to Teal Bldg Line 1 |
| Type of Work | N02F | SK1205 Agitator Removeable Unit Line 1 |
| Type of Work | N02G | SK1301 Reactor Structure |
| Type of Work | N02H | SK1304 Connection Str. to Teal Bldg Line 2 |
| Type of Work | N02I | SK1303 Connec. Str. to Extrusion Building |
| Type of Work | N02J | SK1305 Agitator Removeable Unit Line2 |
| Type of Work | N02K | SK1101 Offgas Compressor Bldg |
| Type of Work | N02M | Auxiliary/Monorails/Crane Structures inside Extruder Room |
| Type of Work | N02O | SK1705/09 Platforms/Frames inside Extrusion Building |
| Type of Work | N02P | SK1202 Teal Bldg Line 1 |
| Type of Work | N02Q | SK1302 Teal Bldg Line 2 |
| Type of Work | N02R | SK1206 Catalyst Bldg Line 1 |
| Type of Work | N02S | SK1702 Extruder Building Entrance Hall |
| Type of Work | N02T | SK1703 Purge Bin Structure +94m |
| Type of Work | N02U | SK1704 Piperack inside Extrusion Building |
| Type of Work | N02V | SR1707 Connect. Piperack to CA12 |
| Type of Work | N02W | SR1708 Connect. Piperack to CA13 |
| Type of Work | N02X | SK1001 PRU Section |
| Type of Work | N02Y | SK3101 Silo Structure |
| Type of Work | N02Z | SK3104 Blower-/Truck Loading Section |
| Type of Work | N02~ | SK1801 Central Chiller Unit Structure |
| Type of Work | N02§ | SK1706 Extr Bldg Cladding Support Structure |
| Type of Work | N02Д | SK3103 Service Area |
| Type of Work | N02Ц | SK3102 Warehouse |
| Type of Work | N02Ь | SK1402 Flare Section |
| Type of Work | PU02 | Additive Feed System Components |
| Type of Work | PU05 | Big Bag Powder Loading Station |
| Type of Work | PU06 | Mobile FFS Bagging System BG-31201 |
| Type of Work | PU07 | Pallet Packaging & Palletizing System XX-31229 |
| Type of Work | PU10 | Conveying System |
| Type of Work | PU12 | Propylene Recovery Unit |
| Type of Work | PU15 | Reactor Seal Oil Package |
| Type of Work | PU22 | Vacuum System |
| Type of Work | R01 | Post Indicator Valves |
| Type of Work | R02 | UG Piping - GFK Piping Material |
| Type of Work | R02A | UG Piping - Cast Iron Piping Material |
| Type of Work | R02B | UG Piping - HDPE Piping Material |
| Type of Work | R03A | Bolting Material |
| Type of Work | R03B | Gaskets |
| Type of Work | R04 | AG Piping Ball-,Gate-,Globe-,Butterfly Valves |
| Type of Work | R04A | AG Piping Piston RAM Valves |
| Type of Work | R06 | AG Fittings CS |
| Type of Work | R06A | AG Fittings SS |
| Type of Work | R06B | AG Pipes CS |
| Type of Work | R06C | AG Pipes SS |
| Type of Work | R06D | AG Flanges CS/SS |
| Type of Work | R07A | Standard Pipe Supports |
| Type of Work | R07B | Special Pipe Supports |
| Type of Work | R09A | Cycle Gas Expansion Joints |
| Type of Work | R09B | Air Manifolds |
| Type of Work | S01 | Safety Relief Valves |
| Type of Work | S02 | Rupture Disks |
| Type of Work | S05 | Gas Extinguishing System |
| Type of Work | S06 | Sprinkler System |
| Type of Work | S07 | Water Spray Deluge System |
| Type of Work | S08A | Hydrants |
| Type of Work | S08B | Monitors |
| Type of Work | S09 | MINOR FIRE FIGHTING EQUIPMENT |
| Type of Work | S10 | Flame Arrestors |
| Type of Work | XNK | Steel Structure for Equipment |
| UPT | IMS | Integrated Management Schedule |
| UPT | LND | Linde |
| UPT | OWN | Owner |
| UPT | PMT | Sibur/Fluor |
| WBS Discipline | 0A | General Milestones |
| WBS Discipline | 0B | General Activities |
| WBS Discipline | A | Project Management |
| WBS Discipline | B | Mechanical - Stationary Equipment |
| WBS Discipline | C | Civil |
| WBS Discipline | E | Electrical |
| WBS Discipline | H | HVAC |
| WBS Discipline | J | Instrumentation |
| WBS Discipline | L | Plant Design |
| WBS Discipline | M | Mechanical - Rotating Equipment |
| WBS Discipline | N | Structural Steel |
| WBS Discipline | P | Process |
| WBS Discipline | Q | Quality Planning/ Qualtity Assurance |
| WBS Discipline | R | Piping |
| WBS Discipline | S | Safety & Environment |
| WBS Discipline | T | Turnover Engineering |
| WBS Discipline | U | Package Units |
| WBS Discipline | V | Insulation |
| WBS Discipline | W | Painting |
| WBS Objects | 0000 | Generals - all CA's |
| WBS Objects | 1010 | Propylene Recovery Unit Area - CA10 |
| WBS Objects | 1100 | Generals CA11 |
| WBS Objects | 1104 | Structures inside Offgas Compr Bldg - CA11 |
| WBS Objects | 1110 | Offgas Compressor Building - CA11 |
| WBS Objects | 1111 | Offgas Compressor Filter Section - CA11 |
| WBS Objects | 1200 | Generals - CA12 |
| WBS Objects | 1201 | Reactor Structure - CA12 |
| WBS Objects | 1204 | Connection Structure Reactor to Teal Bldg - CA12 |
| WBS Objects | 1205 | Agitator Removable Unit - CA12 |
| WBS Objects | 1221 | Catalyst Building Line 1 - CA12 |
| WBS Objects | 1222 | Teal Building Line 1 - CA12 |
| WBS Objects | 1230 | Other Ground Based Eqpt - CA12 |
| WBS Objects | 1232 | Recycle Gas Compressor - CA12 |
| WBS Objects | 1233 | Bleed Booster Compressor - CA12 |
| WBS Objects | 1300 | Generals - CA13 |
| WBS Objects | 1301 | Reactor Structure - CA13 |
| WBS Objects | 1303 | Connection Structure to Extruder Bldg. - CA13 |
| WBS Objects | 1304 | Connection Structure Reactor to Teal Bldg - CA13 |
| WBS Objects | 1305 | Agitator Removable Unit - CA13 |
| WBS Objects | 1321 | Catalyst Building Line 2 - CA13 |
| WBS Objects | 1322 | Teal Building Line 2 - CA13 |
| WBS Objects | 1330 | Other Ground Based Eqpt - CA13 |
| WBS Objects | 1332 | Recycle Gas Compressor - CA13 |
| WBS Objects | 1400 | Generals - CA14 |
| WBS Objects | 1410 | Flare Package - CA14 |
| WBS Objects | 1420 | Flare Knockout Drum Section - CA14 |
| WBS Objects | 1500 | Generals - CA15 |
| WBS Objects | 1510 | Air Buffer Vessel Section - CA15 |
| WBS Objects | 1511 | Sanitary Lifting Station Section - CA15 |
| WBS Objects | 1600 | Generals - CA16 |
| WBS Objects | 1610 | Substation / RIE's - CA16 |
| WBS Objects | 1700 | Generals - CA17 |
| WBS Objects | 1701 | Auxiliary/Monorail/Crane Structures - CA17 |
| WBS Objects | 1704 | Internal Pipe Racks - CA17 |
| WBS Objects | 1705 | Internal Platforms & Frames - CA17 |
| WBS Objects | 1706 | Cladding Support Structure & Cladding - CA17 |
| WBS Objects | 1707 | Connection Piperack - CA17 to CA12 |
| WBS Objects | 1708 | Connection Piperack - CA17 to CA13 |
| WBS Objects | 1710 | Extrusion Bldg 1st Floor +98,650m (+0,15m) - CA17 |
| WBS Objects | 1718 | Extrusion Bldg 2nd Floor +111,250m (+12,75m) - CA17 |
| WBS Objects | 1720 | Extrusion Bldg 3rd Floor +117,550m (+19,05m) - CA17 |
| WBS Objects | 1730 | Extrusion Bldg 4th Floor +123,850m (+25,35m) - CA17 |
| WBS Objects | 1736 | Extrusion Bldg 5th Floor +130,150m (+31,65m) - CA17 |
| WBS Objects | 1740 | Extrusion Bldg 6th Floor +136,450m (+37,95m) - CA17 |
| WBS Objects | 1760 | Purge Bin Structure +189,245m (+90,75m) - CA17 |
| WBS Objects | 1770 | Entrance Hall southside - CA17 |
| WBS Objects | 1810 | Central Chiller Unit Area - CA18 |
| WBS Objects | 3100 | Generals - CA31 |
| WBS Objects | 3110 | Silo Structure - CA31 |
| WBS Objects | 3115 | Conveying Tower - CA31 |
| WBS Objects | 3120 | Blower Room & Truck Inliner Loading - CA31 |
| WBS Objects | 3130 | Service Area - CA31 |
| WBS Objects | 3140 | Warehouse - CA31 |
| WBS Objects | 4100 | Generals - CA41 |
| WBS Objects | 5101 | Pipe Rack 1 - Part 1 - CA51 |
| WBS Objects | 5102 | Pipe Rack 1 - Part 2 - CA51 |
| WBS Objects | 5103 | Pipe Rack 1 - Part 3 - CA51 |
| WBS Objects | 5104 | Pipe Rack 1 - Part 4 - CA51 |
| WBS Objects | 5201 | Pipe Rack 2 - CA52 |
| WBS Objects | 5301 | Pipe Rack 3 - CA53 |
| WBS Objects | 5401 | Pipe Rack 4 - Part 1 - CA54 |
| WBS Objects | 5402 | Pipe Rack 4 - Part 2 - CA54 |
| WBS Objects | 5501 | Pipe Rack 5 - Part 1 - CA55 |
| WBS Objects | 5502 | Pipe Rack 5 - Part 2 - CA55 |
| WBS Objects | 5503 | Pipe Rack 5 - Part 3 - CA55 |
| WBS Objects | 5601 | Pipe Rack 6 - CA56 |
| WBS Objects | 90 | U/G Systems - CA90 |
| WBS Objects | 90A | U/G Syst. - CA90 - Oily Waste Water Sewer S. |
| WBS Objects | 90C | U/G Syst. - CA90 - Sanitary Waste Water Sewer S. |
| WBS Objects | 90D | U/G Syst. - CA90 - Medium Pressure Firewater S. |
| WBS Objects | 90E | U/G Syst. - CA90 - Potable Water Syst. |
| WBS Objects | 90F | U/G Syst. - CA90 - Service Water Syst. |
| WBS Objects | 90G | U/G Syst. - CA90 - Overall |
| WBS Objects | 90H | U/G Syst. - CA90 - High Pressure Firewater S. |
| WBS Objects | 9600 | Concrete Paving - CA96 |
| WBS Objects | 98 | Miscellaneous - CA98 |
| WBS Objects | LUTZ | Construction General |
| WBS Objects | LUZ1 | Lutz Kern - Procurement |
| WBS Objects | LUZ2 | General ( ) |
| WBS Phase | 0 | Project Phases - General |
| WBS Phase | E | Engineering |
| WBS Phase | P | Procurement |
| WBS Phase | X | Construction |
| WBS Type of Work | 0000 | Engineering - General |
| WBS Type of Work | E020 | Engineering - Construction Concept |
| WBS Type of Work | EB05 | Eng Stat Eqpt - Final Loads for Civil /Str.Steel |
| WBS Type of Work | EB13 | Eng Stat Eqpt - Vessels/Drums Inquiry Specs |
| WBS Type of Work | EB14 | Eng Stat Eqpt - Vessels/Drums PO-Specs |
| WBS Type of Work | EB15 | Eng Stat Eqpt - Vendor Eng & Review |
| WBS Type of Work | EB19 | Eng Stat Eqpt - Vessels/Drums As Built |
| WBS Type of Work | EB23 | Eng Stat Eqpt - Exchanger Inquiry Specs |
| WBS Type of Work | EB24 | Eng Stat Eqpt - Exchanger PO-Specs |
| WBS Type of Work | EB25 | Eng Stat Eqpt - Exchanger Vendor Eng & Review |
| WBS Type of Work | EB34 | Eng Stat Eqpt - Reactors PO-Specs |
| WBS Type of Work | EB35 | Eng Stat Eqpt - Reactors Vendor Eng & Review |
| WBS Type of Work | EB44 | Eng Stat Eqpt - Columns PO-Specs |
| WBS Type of Work | EB45 | Eng Stat Eqpt - Columns Vendor Eng & Review |
| WBS Type of Work | EB64 | Eng Stat Eqpt - Silos PO-Specs |
| WBS Type of Work | EB65 | Eng Stat Eqpt - Silos Vendor Eng &Review |
| WBS Type of Work | EB84 | Eng Stat Eqpt - Filters PO-Specs |
| WBS Type of Work | EB85 | Eng Stat Eqpt - Filters Vendor Eng &Review |
| WBS Type of Work | EB93 | Eng Stat Eqpt - Misc Inquiry Specs |
| WBS Type of Work | EB94 | Eng Stat Eqpt - Misc PO-Specs |
| WBS Type of Work | EB95 | Eng Stat Eqpt - Misc Vendor Eng &Review |
| WBS Type of Work | EC00 | Eng Civil - General |
| WBS Type of Work | EC07 | Eng Civil - Check & release of working drwgs (AFC) |
| WBS Type of Work | EC13 | Eng Civil - Fire Safety Survey |
| WBS Type of Work | EC15 | Eng Civil - Piling |
| WBS Type of Work | EC22 | Eng Civil - Foundation Loads |
| WBS Type of Work | EC24 | Eng Civil - Foundation Data Sheets (FDS) |
| WBS Type of Work | EC26 | Eng Civil - Static Calc Foundation |
| WBS Type of Work | EC28 | Eng Civil - Formwork/Reinforcment Drwgs |
| WBS Type of Work | EC30 | Eng Civil - UG Installations |
| WBS Type of Work | EC31 | Eng Civil - UG - Oily Water Sewer System |
| WBS Type of Work | EC33 | Eng Civil - UG - Sanitary Waste Water Sewer Sys. |
| WBS Type of Work | EC34 | Eng Civil - UG - Medium Pressure Firewater Sys. |
| WBS Type of Work | EC37 | Eng Civil - UG - Potable Water System |
| WBS Type of Work | EC38 | Eng Civil - UG - Service Water System |
| WBS Type of Work | EC39 | Eng Civil - UG - Overall |
| WBS Type of Work | EC42 | Eng Civil - Building & Struc Concept |
| WBS Type of Work | EC44 | Eng Civil - Building Layout |
| WBS Type of Work | EC45 | Eng Civil - Building /Structure Layout |
| WBS Type of Work | EC46 | Eng Civil - Static Calc Bldg |
| WBS Type of Work | EC48 | Eng Civil - Formwork/Reinforcement Drwgs |
| WBS Type of Work | EC50 | Eng Civil - Architectural Detail Drawings |
| WBS Type of Work | EC52 | Eng Civil - False Floor |
| WBS Type of Work | EC60 | Eng Civil - Paving |
| WBS Type of Work | EC70 | Eng Civil - Structural Steel |
| WBS Type of Work | EE00 | Eng Electr - General |
| WBS Type of Work | EE11 | Eng Electr - prel. Loads for Civil / StrSteel |
| WBS Type of Work | EE12 | Eng Electr - Final Loads for Civil / StrSteel |
| WBS Type of Work | EE19 | Eng Electr -Trafo,SG's,MCC's General |
| WBS Type of Work | EE20 | MV-/LV Swg/Transformer/Busducts/LV-VFD's |
| WBS Type of Work | EE21 | Motors for Gear Unit |
| WBS Type of Work | EE24 | UPS |
| WBS Type of Work | EE25 | Lighting Panel |
| WBS Type of Work | EE26 | MV Cable |
| WBS Type of Work | EE27 | Power Controller |
| WBS Type of Work | EE28 | Earthing |
| WBS Type of Work | EE29 | Cable Trays |
| WBS Type of Work | EE30 | LV Cable |
| WBS Type of Work | EE31 | Eng. Electr.-Electr. Field Equipment General |
| WBS Type of Work | EE33 | Lighting |
| WBS Type of Work | EE34 | Distribution Panel |
| WBS Type of Work | EE36 | Eng Electr - Local Switches |
| WBS Type of Work | EE37 | Cable Glands |
| WBS Type of Work | EE39 | Eng Electr - Heat Tracing |
| WBS Type of Work | EE40 | Eng Electr - Fire Detection (PMT Scope) |
| WBS Type of Work | EE43 | Eng Electr - Communication System (PMT Scope) |
| WBS Type of Work | EE44 | Diesel Generator |
| WBS Type of Work | EE46 | Eng Electr - Cable Trays CAD-Model & drwgs |
| WBS Type of Work | EE50 | Eng Electr - Cables General |
| WBS Type of Work | EE52 | Aviation Lights |
| WBS Type of Work | EE56 | Eng Electr - Cable Routing Details |
| WBS Type of Work | EE70 | Eng Electr - Lighting&Small Power General |
| WBS Type of Work | EE76 | Eng Electr - Lighting&Small Power Dwgs |
| WBS Type of Work | EE80 | Eng Electr - Heat Tracing General |
| WBS Type of Work | EE90 | Eng Electr - Grounding Systems |
| WBS Type of Work | EF05 | Safefty Review |
| WBS Type of Work | EF10 | Piping & Instrumentation Diagrams |
| WBS Type of Work | EF15 | Pipeline List's |
| WBS Type of Work | EF20 | Data Sheets for Instrumentation (MSB) |
| WBS Type of Work | EF25 | Functional Design |
| WBS Type of Work | EF28 | DCS/SIS Design |
| WBS Type of Work | EF40 | Specifications |
| WBS Type of Work | EF50 | Piping/Interface Lists |
| WBS Type of Work | EF60 | Precomm.-/Commissioning Planning |
| WBS Type of Work | EH11 | Eng HVAC - prel. Loads for Civil / StrSteel |
| WBS Type of Work | EH12 | Eng HVAC - Final Loads for Civil / StrSteel |
| WBS Type of Work | EH13 | Eng HVAC - Inquiry Spec |
| WBS Type of Work | EH20 | Eng HVAC - Building Requirements & Layouts |
| WBS Type of Work | EH24 | Eng HVAC - Building Openings |
| WBS Type of Work | EH30 | Eng HVAC - HVAC & Plumbing Details (AFC) |
| WBS Type of Work | EH40 | Eng HVAC - HVAC & Plumbing Calculations/Flow Diagramms |
| WBS Type of Work | EJ00 | Eng Instr - General |
| WBS Type of Work | EJ11 | Eng Instr - prel. Loads for Civil / StrSteel |
| WBS Type of Work | EJ12 | Eng Instr - Final Loads for Civil / StrSteel |
| WBS Type of Work | EJ14 | Eng Instr - Building Room Layout |
| WBS Type of Work | EJ16 | Eng Instr - Functional Design |
| WBS Type of Work | EJ23 | Eng Instr - Automation System Inquiry Specs |
| WBS Type of Work | EJ24 | Eng Instr - Automation System PO-Specs |
| WBS Type of Work | EJ25 | Eng Instr - Automation System Vendor Eng & Rev |
| WBS Type of Work | EJ33 | Eng Instr - Field Instruments Inquiry Specs |
| WBS Type of Work | EJ34 | Eng Instr - Field Instruments PO-Specs |
| WBS Type of Work | EJ35 | Eng Instr - Field Instruments Vendor Eng &Review |
| WBS Type of Work | EJ36 | Eng Instr - Field Instruments Hook-up drwgs |
| WBS Type of Work | EJ37 | Eng Instr - Field Instruments Location drwgs |
| WBS Type of Work | EJ41 | Eng Instr - Cable Trays Layout Plan |
| WBS Type of Work | EJ43 | Eng Instr - Cable Trays Inquiry Specs |
| WBS Type of Work | EJ54 | Eng Instr - Cable PO-Specs |
| WBS Type of Work | EJ80 | Eng Instr - Loop Diagrams |
| WBS Type of Work | EM00 | Eng Rot Eqpt - General |
| WBS Type of Work | EM05 | Eng Rot Eqpt - Final Loads for Civil /Str.Steel |
| WBS Type of Work | EM13 | Eng Rot Eqpt - Compressors Inquiry Specs |
| WBS Type of Work | EM14 | Eng Rot Eqpt - Compressors PO-Specs |
| WBS Type of Work | EM15 | Eng Rot Eqpt - Compressors Vendor Eng & Review |
| WBS Type of Work | EM23 | Eng Rot Eqpt - Pumps Inquiry Specs |
| WBS Type of Work | EM24 | Eng Rot Eqpt - Pumps PO-Specs |
| WBS Type of Work | EM25 | Eng Rot Eqpt - Pumps Vendor Eng & Review |
| WBS Type of Work | EM34 | Eng Rot Eqpt - Extruder PO-Specs |
| WBS Type of Work | EM35 | Eng Rot Eqpt - Extruder Vendor Eng & Review |
| WBS Type of Work | EM93 | Eng Rot Eqpt - Misc Inquiry Specs |
| WBS Type of Work | EM94 | Eng Rot Eqpt - Misc PO-Specs |
| WBS Type of Work | EM95 | Eng Rot Eqpt - Misc Vendor Eng & Review |
| WBS Type of Work | EN00 | Eng Struc Steel - General |
| WBS Type of Work | EN15 | Eng Struc Steel - CAD Model / Concepts |
| WBS Type of Work | EN21 | Eng Struc Steel - Prim Steel GA Drwgs+Load Data |
| WBS Type of Work | EN24 | Eng Struc Steel - Prim Steel Static Calculation |
| WBS Type of Work | EN25 | Eng Struc Steel - Prim Steel Loads for Civil |
| WBS Type of Work | EN26 | Eng Struc Steel - Prim Steel Layout Drwgs |
| WBS Type of Work | EN27 | Eng Struc Steel - Prim Steel Layout KM-Drwgs |
| WBS Type of Work | EN28 | Eng Struc Steel - Prim Steel Vendor Eng & Review |
| WBS Type of Work | EN64 | Eng Struc Steel - Check of Gratings Cut-Out drwgs |
| WBS Type of Work | EN65 | Eng Struc Steel - Check of Grating Fabrication drwgs |
| WBS Type of Work | EN67 | Eng Struc Steel - Gratings Cut-Out drwgs |
| WBS Type of Work | EN68 | Eng Struc Steel - Grating Fabrication drwgs |
| WBS Type of Work | EN80 | Eng Struc Steel - Cladding drwgs |
| WBS Type of Work | EN81 | Eng Struc Steel - Check Cladding drwgs |
| WBS Type of Work | EP20 | Process studies/calculations |
| WBS Type of Work | EP30 | Process specifications |
| WBS Type of Work | EP40 | Process Flow Diagrams |
| WBS Type of Work | ER00 | Eng Piping - General |
| WBS Type of Work | ER15 | Eng Piping - Conceptual Piping |
| WBS Type of Work | ER16 | Eng Piping - Loads for Civil |
| WBS Type of Work | ER19 | Eng Piping - Final Loads for Civil |
| WBS Type of Work | ER23 | Eng Piping - Piping Mat. Inquiry Specs |
| WBS Type of Work | ER24 | Eng Piping - Piping Mat. PO-Specs |
| WBS Type of Work | ER25 | Eng Piping - Piping Mat. Vendor Engineering |
| WBS Type of Work | ER29 | Eng Piping - Plotplan Issue |
| WBS Type of Work | ER30 | Eng Piping - CAD Model Piping / Equipment |
| WBS Type of Work | ER33 | Eng Piping - CAD Model Design Review 30% |
| WBS Type of Work | ER36 | Eng Piping - CAD Model Design Review 60% |
| WBS Type of Work | ER39 | Eng Piping - CAD Model Design Review 90% |
| WBS Type of Work | ER42 | Eng Piping - Stress Analysis |
| WBS Type of Work | ER44 | Eng Piping - U/G Isometric Production CA90 |
| WBS Type of Work | ER45 | Eng Piping - Isometric Production (above ground) |
| WBS Type of Work | ER47 | Eng Piping - Piping Layout Plans |
| WBS Type of Work | ER49 | Eng Piping - Check Isometric and Release |
| WBS Type of Work | ES10 | Eng Safety - Safety Studies |
| WBS Type of Work | ES20 | Eng Safety - Safety Material General |
| WBS Type of Work | ES23 | Eng Safety - Safety Material Inquiry Specs |
| WBS Type of Work | ES24 | Eng Safety - Safety Material PO-Specs |
| WBS Type of Work | EU13 | Eng PU's - Conveying Syst. Inquiry Specs |
| WBS Type of Work | EU14 | Eng PU's - Conveying Syst. PO-Specs |
| WBS Type of Work | EU15 | Eng PU's - Conveying Syst. Vendor Eng&Review |
| WBS Type of Work | EU24 | Eng PU's - Additive Syst. PO-Specs |
| WBS Type of Work | EU25 | Eng PU's - Additive Syst. Vendor Eng&Review |
| WBS Type of Work | EU33 | Eng PU's - Bagging/Packaging Inquiry Specs |
| WBS Type of Work | EU34 | Eng PU's - Bagging/Packaging PO-Specs |
| WBS Type of Work | EU35 | Eng PU's - Bagging/Packaging Vendor Eng&Review |
| WBS Type of Work | EU93 | Eng PU's - Other Pck. Inquiry Specs |
| WBS Type of Work | EU94 | Eng PU's - Other Pck. PO-Specs |
| WBS Type of Work | EU95 | Eng PU's - Other Pck. Eng&Review |
| WBS Type of Work | PB11 | Proc Stat Eqpt - Vessels/Drums Inquiry (RFQ) |
| WBS Type of Work | PB12 | Proc Stat Eqpt - Vessels/Drums Eval./Negotiation |
| WBS Type of Work | PB13 | Proc Stat Eqpt - Vessels/Drum Purchase Order |
| WBS Type of Work | PB16 | Proc Stat Eqpt - Vessels/Drums Fabrication |
| WBS Type of Work | PB17 | Proc Stat Eqpt - Vessels/Drums Expediting |
| WBS Type of Work | PB18 | Proc Stat Eqpt - Vessels/Drums Transport to Site |
| WBS Type of Work | PB19 | Proc Stat Eqpt - Vessels/Drums Arrival at Site |
| WBS Type of Work | PB21 | Proc Stat Eqpt - Exchanger Inquiry (RFQ) |
| WBS Type of Work | PB22 | Proc Stat Eqpt - Exchanger ProcEval./Negotiation |
| WBS Type of Work | PB23 | Proc Stat Eqpt - Exchanger Purchase Order |
| WBS Type of Work | PB26 | Proc Stat Eqpt - Exchanger Fabrication |
| WBS Type of Work | PB27 | Proc Stat Eqpt - Exchanger Expediting |
| WBS Type of Work | PB28 | Proc Stat Eqpt - Exchanger Transport to Site |
| WBS Type of Work | PB29 | Proc Stat Eqpt - Exchanger Arrival at Site |
| WBS Type of Work | PB31 | Proc Stat Eqpt - Reactors Inquiry (RFQ) |
| WBS Type of Work | PB32 | Proc Stat Eqpt - Reactors Evaluation/Negotiation |
| WBS Type of Work | PB33 | Proc Stat Eqpt - Reactors Purchase Order (PO) |
| WBS Type of Work | PB36 | Proc Stat Eqpt - Reactors Fabrication |
| WBS Type of Work | PB37 | Proc Stat Eqpt - Reactors Expediting |
| WBS Type of Work | PB38 | Proc Stat Eqpt - Reactors Transport to Site |
| WBS Type of Work | PB39 | Proc Stat Eqpt - Reactors Arrival at Site |
| WBS Type of Work | PB41 | Proc Stat Eqpt - Columns Inquiry (RFQ) |
| WBS Type of Work | PB42 | Proc Stat Eqpt - Columns Evaluation/Negotiation |
| WBS Type of Work | PB43 | Proc Stat Eqpt - Columns Purchase Order (PO) |
| WBS Type of Work | PB46 | Proc Stat Eqpt - Columns Fabrication |
| WBS Type of Work | PB47 | Proc Stat Eqpt - Columns Expediting |
| WBS Type of Work | PB48 | Proc Stat Eqpt - Columns Transport to Site |
| WBS Type of Work | PB49 | Proc Stat Eqpt - Columns Arrival at Site |
| WBS Type of Work | PB61 | Proc Stat Eqpt - Silos Inquiry (RFQ) |
| WBS Type of Work | PB62 | Proc Stat Eqpt - Silos Evaluation/Negotiation |
| WBS Type of Work | PB63 | Proc Stat Eqpt - Silos Purchase Order (PO) |
| WBS Type of Work | PB66 | Proc Stat Eqpt - Silos Fabrication |
| WBS Type of Work | PB67 | Proc Stat Eqpt - Silos Expediting |
| WBS Type of Work | PB68 | Proc Stat Eqpt - Silos Transport to Site |
| WBS Type of Work | PB69 | Proc Stat Eqpt - Silos Arrival at Site |
| WBS Type of Work | PB81 | Proc Stat Eqpt - Filters Inquiry (RFQ) |
| WBS Type of Work | PB82 | Proc Stat Eqpt - Filters Evaluation/Negotiation |
| WBS Type of Work | PB83 | Proc Stat Eqpt - Filters Purchase Order (PO) |
| WBS Type of Work | PB86 | Proc Stat Eqpt - Filters Fabrication |
| WBS Type of Work | PB87 | Proc Stat Eqpt - Filters Expediting |
| WBS Type of Work | PB88 | Proc Stat Eqpt - Filters Transport to Site |
| WBS Type of Work | PB89 | Proc Stat Eqpt - Filters Arrival at Site |
| WBS Type of Work | PB91 | Proc Stat Eqpt - Misc Eqpt Inquiry (RFQ) |
| WBS Type of Work | PB92 | Proc Stat Eqpt - Misc Eqpt Evaluation/Negotiatio |
| WBS Type of Work | PB93 | Proc Stat Eqpt - Misc Eqpt Purchase Order (PO) |
| WBS Type of Work | PB96 | Proc Stat Eqpt - Misc Eqpt Fabrication |
| WBS Type of Work | PB97 | Proc Stat Eqpt - Misc Eqpt Expediting |
| WBS Type of Work | PB98 | Proc Stat Eqpt - Misc Eqpt Transport to Site |
| WBS Type of Work | PB99 | Proc Stat Eqpt - Misc Eqpt Arrival at Site |
| WBS Type of Work | PE00 | Proc Electrical - General |
| WBS Type of Work | PE93 | Proc Electr - Other Systems Purchase Order (PO) |
| WBS Type of Work | PH11 | Proc HVAC - Inquiry (RFQ) |
| WBS Type of Work | PH13 | Proc HVAC - Purchase Order (PO) |
| WBS Type of Work | PH15 | Proc HVAC - Vendor Procurement |
| WBS Type of Work | PH16 | Proc HVAC - Fabrication |
| WBS Type of Work | PH18 | Proc HVAC - Transport to Site |
| WBS Type of Work | PH19 | Proc HVAC - Arrival at Site |
| WBS Type of Work | PJ21 | Proc Instrum. - PLS Inquiry (RFQ) |
| WBS Type of Work | PJ22 | Proc Instrum. - PLS Evaluation/Negotiation |
| WBS Type of Work | PJ23 | Proc Instrum. - PLS Purchase Order (PO) |
| WBS Type of Work | PJ26 | Proc Instrum. - PLS Fabrication |
| WBS Type of Work | PJ27 | Proc Instrum. - PLS Expediting |
| WBS Type of Work | PJ28 | Proc Instrum. - PLS Transport to Site |
| WBS Type of Work | PJ29 | Proc Instrum. - PLS Arrival at Site |
| WBS Type of Work | PJ31 | Proc Instrum. - Field Instruments Inquiry (RFQ) |
| WBS Type of Work | PJ32 | Proc Instrum. - Field Instr. Evaluation/Negotiat |
| WBS Type of Work | PJ33 | Proc Instrum. - Field Instr. Purchase Order (PO) |
| WBS Type of Work | PJ36 | Proc Instrum. - Field Instruments Fabrication |
| WBS Type of Work | PJ37 | Proc Instrum. - Field Instruments PLS Expediting |
| WBS Type of Work | PJ38 | Proc Instrum. - Field Instr. Transport to Site |
| WBS Type of Work | PJ39 | Proc Instrum. - Field Instr. Arrival at Site |
| WBS Type of Work | PJ52 | Proc Instrum. - Cables Evaluation/Negotiation |
| WBS Type of Work | PJ59 | Proc Instrum. - Cables Arrival at Site |
| WBS Type of Work | PM11 | Proc Rot Eqpt - Compressors Inquiry (RFQ) |
| WBS Type of Work | PM12 | Proc Rot Eqpt - Compressors Eval./Negotiation |
| WBS Type of Work | PM13 | Proc Rot Eqpt - Compressors Purchase Order (PO) |
| WBS Type of Work | PM16 | Proc Rot Eqpt - Compressors Fabrication |
| WBS Type of Work | PM17 | Proc Rot Eqpt - Compressors Inspection |
| WBS Type of Work | PM18 | Proc Rot Eqpt - Compressors Transport to Site |
| WBS Type of Work | PM19 | Proc Rot Eqpt - Compressors Arrival at Site |
| WBS Type of Work | PM21 | Proc Rot Eqpt - Pumps Inquiry (RFQ) |
| WBS Type of Work | PM22 | Proc Rot Eqpt - Pumps Evaluation/Negotiation |
| WBS Type of Work | PM23 | Proc Rot Eqpt - Pumps Purchase Order (PO) |
| WBS Type of Work | PM26 | Proc Rot Eqpt - Pumps Fabrication |
| WBS Type of Work | PM27 | Proc Rot Eqpt - Pumps Inspection |
| WBS Type of Work | PM28 | Proc Rot Eqpt - Pumps Transport to Site |
| WBS Type of Work | PM29 | Proc Rot Eqpt - Pumps Arrival at Site |
| WBS Type of Work | PM31 | Proc Rot Eqpt - Extruder Inquiry (RFQ) |
| WBS Type of Work | PM32 | Proc Rot Eqpt - Extruder Evaluation/Negotiation |
| WBS Type of Work | PM33 | Proc Rot Eqpt - Extruder Purchase Order (PO) |
| WBS Type of Work | PM36 | Proc Rot Eqpt - Extruder Fabrication |
| WBS Type of Work | PM37 | Proc Rot Eqpt - Extruder Inspection |
| WBS Type of Work | PM38 | Proc Rot Eqpt - Extruder Transport to Site |
| WBS Type of Work | PM39 | Proc Rot Eqpt - Extruder Arrival at Site |
| WBS Type of Work | PM91 | Proc Rot Eqpt - Misc. Inquiry (RFQ) |
| WBS Type of Work | PM92 | Proc Rot Eqpt - Misc. Evaluation/Negotiation |
| WBS Type of Work | PM93 | Proc Rot Eqpt - Misc. Purchase Order (PO) |
| WBS Type of Work | PM96 | Proc Rot Eqpt - Misc. Fabrication |
| WBS Type of Work | PM97 | Proc Rot Eqpt - Misc. Inspection |
| WBS Type of Work | PM98 | Proc Rot Eqpt - Misc. Transport to Site |
| WBS Type of Work | PM99 | Proc Rot Eqpt - Misc. Arrival at Site |
| WBS Type of Work | PN23 | Proc Str Steel - Prim Steel Purchase Order (PO) |
| WBS Type of Work | PN25 | Proc Str Steel - Prim Steel Vendor Procurement |
| WBS Type of Work | PN26 | Proc Str Steel - Prim Steel Fabrication |
| WBS Type of Work | PN28 | Proc Str Steel - Prim Steel Transport to Site |
| WBS Type of Work | PN29 | Proc Str Steel - Prim Steel Arrival at Site |
| WBS Type of Work | PN66 | Proc Str Steel - Gratings Fabrication |
| WBS Type of Work | PN68 | Proc Str Steel - Gratings Transport to Site |
| WBS Type of Work | PN69 | Proc Str Steel - Gratings Arrival at Site |
| WBS Type of Work | PR20 | Proc Piping - Piping Mat. General |
| WBS Type of Work | PR21 | Proc Piping - Piping Mat. Inquiry (RFQ) |
| WBS Type of Work | PR22 | Proc Piping - Piping Mat. Evaluation/Negotiation |
| WBS Type of Work | PR23 | Proc Piping - Piping Mat. Purchase Order (PO) |
| WBS Type of Work | PR26 | Proc Piping - Piping Mat. Fabrication |
| WBS Type of Work | PR27 | Proc Piping - Piping Mat. Expediting |
| WBS Type of Work | PR28 | Proc Piping - Piping Mat. Transport to Site |
| WBS Type of Work | PR29 | Proc Piping - Piping Mat. Arrival at Site |
| WBS Type of Work | PS21 | Proc Safety - Safety Material Inquiry (RFQ) |
| WBS Type of Work | PS22 | Proc Safety - Safety Material Evaluation/Negotia |
| WBS Type of Work | PS23 | Proc Safety - Safety Material Purchase Order (PO |
| WBS Type of Work | PS26 | Proc Safety - Safety Material Fabrication |
| WBS Type of Work | PS27 | Proc Safety - Safety Material Expediting |
| WBS Type of Work | PS28 | Proc Safety - Safety Material Transport to Site |
| WBS Type of Work | PS29 | Proc Safety - Safety Material Arrival at Site |
| WBS Type of Work | PU11 | Proc PU's - Conveying Syst. Inquiry (RFQ) |
| WBS Type of Work | PU12 | Proc PU's - Conveying Syst. Evaluation/Negotiati |
| WBS Type of Work | PU13 | Proc PU's - Conveying Syst. Purchase Orders (PO) |
| WBS Type of Work | PU16 | Proc PU's - Conveying Syst. Fabrication |
| WBS Type of Work | PU17 | Proc PU's - Conveying Syst. Expediting |
| WBS Type of Work | PU18 | Proc PU's - Conveying Syst. Transport to Site |
| WBS Type of Work | PU19 | Proc PU's - Conveying Syst. Arrival at Site |
| WBS Type of Work | PU21 | Proc PU's - Additive Syst. Inquiry (RFQ) |
| WBS Type of Work | PU22 | Proc PU's - Additive Syst. Evaluation/Negotiatio |
| WBS Type of Work | PU23 | Proc PU's - Additive Syst. Purchase Order (PO) |
| WBS Type of Work | PU26 | Proc PU's - Additive Syst. Fabrication |
| WBS Type of Work | PU27 | Proc PU's - Additive Syst. Expediting |
| WBS Type of Work | PU28 | Proc PU's - Additive Syst. Transport to Site |
| WBS Type of Work | PU29 | Proc PU's - Additive Syst. Arrival at Site |
| WBS Type of Work | PU31 | Proc PU's - Bagging/Packaging Inquiry (RFQ) |
| WBS Type of Work | PU32 | Proc PU's - Bagging/Packaging Eval./Negotiation |
| WBS Type of Work | PU33 | Proc PU's - Bagging/Packaging Purchase Order (PO |
| WBS Type of Work | PU36 | Proc PU's - Bagging/Packaging Fabrication |
| WBS Type of Work | PU37 | Proc PU's - Bagging/Packaging Expediting |
| WBS Type of Work | PU38 | Proc PU's - Bagging/Packaging Transport to Site |
| WBS Type of Work | PU39 | Proc PU's - Bagging/Packaging Arrival at Site |
| WBS Type of Work | PU91 | Proc PU's - Other Pck. Inquiry (RFQ) |
| WBS Type of Work | PU92 | Proc PU's - Other Pck. Evaluation/Negotiation |
| WBS Type of Work | PU93 | Proc PU's - Other Pck. Purchase Order (PO) |
| WBS Type of Work | PU96 | Proc PU's - Other Pck. Fabrication |
| WBS Type of Work | PU97 | Proc PU's - Other Pck. Expediting |
| WBS Type of Work | PU98 | Proc PU's - Other Pck. Transport to Site |
| WBS Type of Work | PU99 | Proc PU's - Other Pck. Arrival at Site |
| WBS Type of Work | X030 | Construction Milestones - Utility Needs |
| WBS Type of Work | XE00 | Elec Installation - General |
| WBS Type of Work | XR40 | Piping - Installation |
| Zeigen/n. Zeigen | 0 | nicht zeigen |
| Zeigen/n. Zeigen | 1 | FEED Document Schedule Activities |
| Zeigen/n. Zeigen | C1 | Civil Engineering View till Sep 09 |
| Zeigen/n. Zeigen | C2 | CA16 Substation |
| Zeigen/n. Zeigen | C3 | Critical Path - Extruder |
| Zeigen/n. Zeigen | C4 | Critical Path - PRU |
| Zeigen/n. Zeigen | C5 | Critical Path - UG Piping |
| Zeigen/n. Zeigen | C6 | Fire-/ Gas Detection System |
| Zeigen/n. Zeigen | C7 | CA31 Storage / Packaging and Shipping Building |
| Zeigen/n. Zeigen | C9 | CA17 Extrusion Building |
| Zeigen/n. Zeigen | EQ | Equipment, itemized |
| Zeigen/n. Zeigen | FL | Flare Package |
| Zeigen/n. Zeigen | L2 | Level 2 PMT |
| Zeigen/n. Zeigen | M1 | Milestones Level 1 Schedule |
