# Tobolsk-A3JI-PP-Plant 500 kt/a (current) _ C Construction / Comm_DD 20110827

Schedule from Primavera P6, 2008-09-24 to 2013-04-10, data date 2011-08-27, costs in EUR, A marks actual dates.
110710 Bereinigung durch neue Kopie von EP/C mit den Baselines / 110709 Fehler nach Import / Update EP aus Dresden (Doppelte Relationships / !!)

## Calendars

- TB26 - 3 - Construct-normal *: Mon-Sat 08:00-12:00, 13:00-17:00; Sun off. Exceptions (off unless hours are given): 2008-12-22 to 2009-01-10, 2009-01-12 to 2009-01-17, 2009-05-01, 2009-12-21 to 2009-12-26 08:00-16:00, 2009-12-27, 2009-12-28 to 2010-01-02 08:00-16:00, 2010-01-03, 2010-01-04 to 2010-01-09 08:00-16:00, 2010-01-10, 2010-01-11 to 2010-01-16 08:00-16:00, 2010-05-01, 2010-11-04, 2011-01-01, 2011-01-03 to 2011-01-08, 2011-02-23, 2011-03-08, 2011-05-02, 2011-05-09, 2011-06-13, 2011-11-04, 2012-01-01 to 2012-01-07, 2012-02-23, 2012-03-08, 2012-05-01, 2012-05-09, 2012-06-12, 2012-11-05, 2012-12-25 to 2012-12-26, 2013-01-01 to 2013-01-05, 2013-01-07, 2013-02-23, 2013-03-08.
- TB26 - V - Construct-Winter partly *: Mon-Sat 08:00-12:00, 13:00-17:00; Sun off. Exceptions (off unless hours are given): 2008-12-22 to 2009-01-10, 2009-01-12 to 2009-01-17, 2009-05-01, 2009-12-05, 2009-12-12, 2009-12-19, 2009-12-21 to 2009-12-25 08:00-16:00, 2009-12-26 to 2009-12-27, 2009-12-28 to 2010-01-01 08:00-16:00, 2010-01-02 to 2010-01-03, 2010-01-04 to 2010-01-08 08:00-16:00, 2010-01-09 to 2010-01-10, 2010-01-11 to 2010-01-15 08:00-16:00, 2010-01-16, 2010-01-23, 2010-01-30, 2010-02-06, 2010-02-13, 2010-02-20, 2010-02-27, 2010-05-01, 2010-11-04 to 2010-11-06, 2010-11-12 to 2010-11-13, 2010-11-19 to 2010-11-20, 2010-11-26 to 2010-11-27, 2010-12-01 08:00-16:00, 2010-12-02 to 2010-12-04, 2010-12-06 to 2010-12-08 08:00-16:00, 2010-12-09 to 2010-12-11, 2010-12-13 to 2010-12-15 08:00-16:00, 2010-12-16 to 2010-12-18, 2010-12-20 to 2010-12-22 08:00-16:00, 2010-12-23 to 2010-12-25, 2010-12-27 to 2010-12-29 08:00-16:00, 2010-12-30 to 2011-01-01, 2011-01-03 to 2011-01-09, 2011-01-13 to 2011-01-15, 2011-01-20 to 2011-01-22, 2011-01-27 to 2011-01-29, 2011-02-03 to 2011-02-05, 2011-02-10 to 2011-02-12, 2011-02-17 to 2011-02-19, 2011-02-23 to 2011-02-26, 2011-03-05, 2011-03-08, 2011-03-12, 2011-03-19, 2011-03-26, 2011-05-02, 2011-05-09, 2011-06-13, 2011-11-04 to 2011-11-05, 2011-11-11 to 2011-11-12, 2011-11-18 to 2011-11-19, 2011-11-25 to 2011-11-26, 2011-12-01 to 2011-12-03, 2011-12-08 to 2011-12-10, 2011-12-15 to 2011-12-17, 2011-12-22 to 2011-12-25, 2011-12-29 to 2012-01-07, 2012-01-12 to 2012-01-14, 2012-01-19 to 2012-01-21, 2012-01-26 to 2012-01-28, 2012-02-02 to 2012-02-04, 2012-02-09 to 2012-02-11, 2012-02-16 to 2012-02-18, 2012-02-23 to 2012-02-25, 2012-03-03, 2012-03-08, 2012-03-10, 2012-03-17, 2012-03-24, 2012-03-31, 2012-05-01, 2012-05-08, 2012-06-12, 2012-11-05, 2012-12-25 to 2012-12-26, 2013-01-01 to 2013-01-05, 2013-01-07, 2013-03-08.
- TB26 - 3 - Construction Normal 7days * CA17: Mon 08:00-16:00; Tue-Sun 08:00-12:00, 13:00-17:00. Exceptions (off unless hours are given): 2008-12-22 to 2009-01-10, 2009-01-12 to 2009-01-17, 2009-05-01, 2009-12-21 to 2009-12-26 08:00-16:00, 2009-12-27, 2009-12-28 to 2010-01-02 08:00-16:00, 2010-01-03, 2010-01-04 to 2010-01-09 08:00-16:00, 2010-01-10, 2010-01-11 to 2010-01-16 08:00-16:00, 2010-05-01, 2010-11-04, 2011-01-01, 2011-01-03 to 2011-01-08, 2011-02-23, 2011-03-08, 2011-05-02, 2011-05-09, 2011-06-13, 2011-11-04, 2012-01-01 to 2012-01-07, 2012-02-23, 2012-03-08, 2012-05-01, 2012-05-09, 2012-06-12, 2012-11-05, 2012-12-25 to 2012-12-26, 2013-01-01 to 2013-01-05, 2013-01-07, 2013-02-23, 2013-03-08.
- TB26 - T - Construct-Winter-3 (Dec/Jan/Feb free) *: Mon-Sat 08:00-12:00, 13:00-17:00; Sun off. Exceptions (off unless hours are given): 2008-12-01 to 2009-01-17, 2009-01-19 to 2009-01-31, 2009-02-02 to 2009-02-28, 2009-05-01, 2009-12-01 to 2010-01-09, 2010-01-11 to 2010-01-30, 2010-02-01 to 2010-02-27, 2010-05-01, 2010-11-04 to 2010-11-06, 2010-11-12 to 2010-11-13, 2010-11-19 to 2010-11-20, 2010-11-26 to 2010-11-27, 2010-12-01 to 2011-01-01, 2011-01-03 to 2011-01-29, 2011-01-31 to 2011-02-26, 2011-02-28, 2011-03-05, 2011-03-08, 2011-03-12, 2011-03-19, 2011-03-26, 2011-05-02, 2011-05-09, 2011-06-13, 2011-11-04 to 2011-11-05, 2011-11-11 to 2011-11-12, 2011-11-18 to 2011-11-19, 2011-11-25 to 2011-11-26, 2011-12-01 to 2011-12-03, 2011-12-05 to 2011-12-10, 2011-12-12 to 2011-12-17, 2011-12-19 to 2012-01-07, 2012-01-09 to 2012-01-14, 2012-01-16 to 2012-01-21, 2012-01-23 to 2012-01-28, 2012-01-30 to 2012-02-04, 2012-02-06 to 2012-02-11, 2012-02-13 to 2012-02-18, 2012-02-20 to 2012-02-25, 2012-02-27 to 2012-02-29, 2012-03-03, 2012-03-08, 2012-03-10, 2012-03-17, 2012-03-24, 2012-03-31, 2012-05-01, 2012-05-08, 2012-06-12, 2012-11-05, 2012-12-25 to 2012-12-26, 2013-01-01 to 2013-01-05, 2013-01-07, 2013-02-23, 2013-03-08.
- TB26 - 2 - Manuf and Delivy: Mon-Sun 08:00-12:00, 13:00-17:00. Exceptions (off unless hours are given): 2008-12-25 to 2008-12-26, 2009-01-01, 2009-05-01, 2009-12-25 to 2009-12-26, 2010-01-01, 2010-05-01, 2010-12-25 to 2010-12-26, 2011-01-01, 2011-05-01, 2011-12-25 to 2011-12-26, 2012-01-01, 2012-05-01, 2012-12-25 to 2012-12-26, 2013-01-01.
- 0 G-7-day work 24h/day: Mon-Sun 08:00-16:00. Exceptions (off unless hours are given): 2008-12-25, 2009-01-01, 2009-07-04, 2009-12-25.
- TB26 - 3 - Construct-winter 7days *: Mon 08:00-16:00; Tue-Sun 08:00-12:00, 13:00-17:00. Exceptions (off unless hours are given): 2008-12-22 to 2009-01-10, 2009-01-12 to 2009-01-17, 2009-05-01, 2009-12-05, 2009-12-12, 2009-12-19, 2009-12-21 to 2009-12-25 08:00-16:00, 2009-12-26 to 2009-12-27, 2009-12-28 to 2010-01-01 08:00-16:00, 2010-01-02 to 2010-01-03, 2010-01-04 to 2010-01-08 08:00-16:00, 2010-01-09 to 2010-01-10, 2010-01-11 to 2010-01-15 08:00-16:00, 2010-01-16, 2010-01-23, 2010-01-30, 2010-02-06, 2010-02-13, 2010-02-20, 2010-02-27, 2010-05-01, 2010-11-04 to 2010-11-06, 2010-11-12 to 2010-11-13, 2010-11-19 to 2010-11-20, 2010-11-26 to 2010-11-27, 2010-12-02 to 2010-12-04, 2010-12-09 to 2010-12-11, 2010-12-16 to 2010-12-18, 2010-12-23 to 2010-12-25, 2010-12-30 to 2011-01-01, 2011-01-03 to 2011-01-09, 2011-01-13 to 2011-01-15, 2011-01-20 to 2011-01-22, 2011-01-27 to 2011-01-29, 2011-02-03 to 2011-02-05, 2011-02-10 to 2011-02-12, 2011-02-17 to 2011-02-19, 2011-02-23 to 2011-02-26, 2011-03-05, 2011-03-08, 2011-03-12, 2011-03-19, 2011-03-26, 2011-05-02, 2011-05-09, 2011-06-13, 2011-11-04 to 2011-11-05, 2011-11-11 to 2011-11-12, 2011-11-18 to 2011-11-19, 2011-11-25 to 2011-11-26, 2011-12-01 to 2011-12-03, 2011-12-08 to 2011-12-10, 2011-12-15 to 2011-12-17, 2011-12-22 to 2011-12-25, 2011-12-29 to 2012-01-07, 2012-01-12 to 2012-01-14, 2012-01-19 to 2012-01-21, 2012-01-26 to 2012-01-28, 2012-02-02 to 2012-02-04, 2012-02-09 to 2012-02-11, 2012-02-16 to 2012-02-18, 2012-02-23 to 2012-02-25, 2012-03-03, 2012-03-08, 2012-03-10, 2012-03-17, 2012-03-24, 2012-03-31, 2012-05-01, 2012-05-08, 2012-06-12, 2012-11-05, 2012-12-25 to 2012-12-26, 2013-01-01 to 2013-01-05, 2013-01-07, 2013-03-08.
- TB26 - 6 - Contract Milest.: Mon-Sun 08:00-12:00, 13:00-17:00. Exceptions (off unless hours are given): 2008-12-25 to 2008-12-26, 2009-01-01, 2009-05-01, 2009-12-25 to 2009-12-26, 2010-05-01, 2010-11-04, 2010-12-25 to 2010-12-26, 2011-01-01, 2011-01-03 to 2011-01-08, 2011-01-17 to 2011-01-31, 2011-02-23, 2011-03-08, 2011-05-01 to 2011-05-02, 2011-05-09, 2011-06-13, 2011-11-04, 2011-12-25 to 2011-12-26, 2012-01-01 to 2012-01-08, 2012-02-23, 2012-03-08, 2012-05-01, 2012-05-09, 2012-06-12, 2012-11-05, 2012-12-25 to 2012-12-26, 2013-01-01 to 2013-01-07, 2013-02-23, 2013-03-08.

## Resources

| Resource | Group | Unit | Rate |
| --- | --- | --- | --- |
| Concrete paved areas & concrete Roads | material | sqm | 180 |
| Gravel | material | sqm | 2 |
| Concrete paved areas & concrete roads | labor |  |  |
| Gravel | labor |  |  |
| Backfill & Compaction | material | cbm | 90 |
| Backfill & Compaction | labor |  |  |
| Piles driven | material | pcs | 300 |
| Piles driven | labor |  |  |
| Cast Iron U/G Piping | material | m | 800 |
| Concrete Manholes | material | pcs | 11000 |
| Floor Drains / Catch Basins | material | pcs | 1000 |
| Fire water hydrants/monitors | material | pcs | 2500 |
| FRP U/G Piping | material | m | 500 |
| Cast iron U/G piping | labor |  |  |
| concrete manholes | labor |  |  |
| floor drains / catch basins | labor |  |  |
| fire water hydrants/ monitors | labor |  |  |
| FRP U/G piping | labor |  |  |
| Concrete works | material | cbm | 1200 |
| Concrete works | labor |  |  |
| Excavation | material | cbm | 40 |
| Excavation | labor |  |  |
| Sub Base for Concrete/Paving&Roads (Gravel) | material | cbm | 100 |
| Subbase for Concrete | labor |  |  |
| Piperacks, Main Structures | material | t | 1700 |
| Piperacks, Main structures | labor |  |  |
| Grating | material | sqm | 150 |
| Grating | labor |  |  |
| Ladders & platforms | material | t | 4000 |
| Ladders & platforms | labor |  |  |
| Flare | material | mhr | 100 |
| Flare | labor |  |  |
| A/G piping field installation | material | Fpi | 250 |
| A/G Piping (Field) | labor |  |  |
| A/G piping prefabrication | material | Fpi | 150 |
| A/G Piping (Prefab) | labor |  |  |
| Grounding & Lightning | material | pcs | 450 |
| Grounding & Lightning | labor |  |  |
| Field Panels | material | pcs | 800 |
| Field panels | labor |  |  |
| Cable trays/conduits | material | m | 120 |
| Cable trays | labor |  |  |
| Cable Pulling | material | m | 20 |
| Cable pulling | labor |  |  |
| Cable connecting | material | pcs | 100 |
| Cable connecting | labor |  |  |
| Electrical Heat Tracing | material | m | 20 |
| Electrical heat tracing | labor |  |  |
| Lighting illuminates | material | pcs | 400 |
| Lighting (iluminates) | labor |  |  |
| Secondary cable trays | material | m | 150 |
| Install secondary cable trays | labor |  |  |
| Termination Field | material | mhr | 100 |
| Termination field | labor |  |  |
| Multicore cables | material | m | 20 |
| Pull multicore cables | labor |  |  |
| Singlecore cables | material | m | 30 |
| Pull singlecore cables | labor |  |  |
| Loop Checks | material | pcs | 200 |
| Loop checks | labor |  |  |
| Junction Boxes/Cabinets/Panels | material | pcs | 1000 |
| Install Junction Boxes/ Cabinets/ Panels | labor |  |  |
| Field Instruments | material | pcs | 220 |
| Install field instruments | labor |  |  |
| Piping painting | material | sqm | 100 |
| Piping painting | labor |  |  |
| Equipment insulation | material | sqm | 500 |
| Equipment insulation | labor |  |  |
| Piping insulation | material | sqm | 300 |
| Piping insulation | labor |  |  |
| Static Equipment < 10 tons | material | t | 4000 |
| Static equipment < 10t | labor |  |  |
| Static Equipment > 10 tons | material | t | 3000 |
| Static equipment >10t | labor |  |  |
| Control & Shut-off valves | material | pcs | 210 |
| Install Control & Shut-off Valves | labor |  |  |
| Fire Detection System | material | mhr | 100 |
| Fire detection system | labor |  |  |
| Communication System | material | mhr | 100 |
| Communication System | labor |  |  |
| Open ditches | material | m | 300 |
| open ditches | labor |  |  |
| Finishing Works - Compressor Building CA11 | material | mhr | 100 |
| Finishing Works - Compressor building CA11 | labor |  |  |
| Precast Concrete Works | material | cbm | 100 |
| Precast concrete works | labor |  |  |
| Cladding | material | sqm | 200 |
| Cladding | labor |  |  |
| HVAC - Compressor Building CA11 | material | mhr |  |
| HVAC - Compressor building CA11 | labor |  |  |
| Rotating Equipment (w/ lube oil unit) | material | t | 4000 |
| Rotating equipment (w/ lube oil unit) | labor |  |  |
| Deluge Piping | material | Fpi | 250 |
| Deluge piping | labor |  |  |
| Fire proofing | material | sqm | 300 |
| Fire proofing | labor |  |  |
| Finishing Works - Teal Buildings CA12/13 | material | mhr | 100 |
| Finishing Works - Teal buildings | labor |  |  |
| HVAC - Teal Buildings CA12/13 | material | mhr |  |
| HVAC - Teal buildings | labor |  |  |
| Finishing Works - Catalyst Buildings CA12/13 | material | mhr | 100 |
| Finishing Works - Catalyst buildings | labor |  |  |
| HVAC - Catalyst Buildings CA12/13 | material | mhr |  |
| HVAC - Catalyst buildings | labor |  |  |
| Rotating Equipment (w/o lube oil unit) | material | t | 3500 |
| Rotating equipment (w/o lube oil unit) | labor |  |  |
| Main Equipment Substations | material | pcs | 1500 |
| Installation main equipment substation | labor |  |  |
| Finishing Works - Substation CA16 | material | mhr | 100 |
| Finishing Works - Substation CA16 | labor |  |  |
| HVAC - Substation CA16 | material | mhr |  |
| HVAC - Substation CA16 | labor |  |  |
| Main Equipment Control Building/RIB | material | mhr | 100 |
| Installation Main Equipment Control Building/RIB | labor |  |  |
| Termination Control Building | material | mhr | 100 |
| Termination Control Building | labor |  |  |
| Finishing Works - Extrusion Building CA17 | material | mhr | 100 |
| Finishing Works - Extrusion building CA17 | labor |  |  |
| HVAC - Extrusion Building CA17 | material | mhr |  |
| HVAC - Extrusion building CA17 | labor |  |  |
| Extruder | material | mhr | 100 |
| Extruder | labor |  |  |
| Conveying S. piping field installation | material | Fpi | 150 |
| Conveying system (Field) | labor |  |  |
| Conveying S. piping prefabrication | material | Fpi | 100 |
| Conveying system (Prefab) | labor |  |  |
| Main cable trays | material | m | 120 |
| Install Main Cable trays | labor |  |  |
| Finishing Works - Warehouse CA31 | material | mhr | 100 |
| Finishing Works - Warehouse CA31 | labor |  |  |
| HVAC - Warehouse CA31 | material | mhr |  |
| HVAC - Warehouse CA31 | labor |  |  |
| Packaging lines | material | mhr | 100 |
| Packaging lines | labor |  |  |
| Asphalt roads | material | sqm | 50 |
| Asphalt Roads | labor |  |  |
| Silos | material | mhr | 100 |
| Silos | labor |  |  |
| Propylene Recovery Unit | material | mhr | 100 |
| Propylene recovery unit | labor |  |  |

## Schedule

| ID | WBS | Activity | Type | Duration | Start | Finish | Predecessors | Complete | Total float | Free float | Constraint | Calendar | Resources | UDF_SAVE ACT ID | UDF_BUDGETED LABOR UNIT | UDF_ACTUAL LABOR UNIT | Department | Constr. Area | PMT-Area | PMT-Schedule Org | PMT-Phase | PMT-Respons. | Zeigen/n. Zeigen | WBS Phase | WBS Discipline | WBS Type of Work | WBS Objects | Russia WBS Discipline (Russia) | Russia Construction Area | Russia WBS Phase | UPT | Russia WBS Objects | IMS | Filter | Type of Work | Inquiry/Order No | PMT-Discipline | PMT-Doc. Type | UDF_CONTRACT INDICATOR | UDF_EXPECTED START | UDF_EXPECTED FINISH | TB26 Ressource Budget | UDF_CHECK CRITICAL PATH | UDF_CHECK BASELINE | MTA |
| --- | --- | --- | --- | --- | --- | --- | --- | --- | --- | --- | --- | --- | --- | --- | --- | --- | --- | --- | --- | --- | --- | --- | --- | --- | --- | --- | --- | --- | --- | --- | --- | --- | --- | --- | --- | --- | --- | --- | --- | --- | --- | --- | --- | --- | --- |
|  | 1 | **PROJECT A3JI** |  |  | 2008-09-24 | 2013-04-10 |  |  |  |  |  |  |  |  |  |  |  |  |  |  |  |  |  |  |  |  |  |  |  |  |  |  |  |  |  |  |  |  |  |  |  |  |  |  |  |
|  | PP | **Area PP** |  |  | 2008-09-24 | 2013-04-10 |  |  |  |  |  |  |  |  |  |  |  |  |  |  |  |  |  |  |  |  |  |  |  |  |  |  |  |  |  |  |  |  |  |  |  |  |  |  |  |
|  | X | **Construction** |  |  | 2008-09-24 | 2012-12-31 |  |  |  |  |  |  |  |  |  |  |  |  |  |  |  |  |  |  |  |  |  |  |  |  |  |  |  |  |  |  |  |  |  |  |  |  |  |  |  |
|  | 0B | **General Activities** |  |  | 2009-09-03 | 2012-12-31 |  |  |  |  |  |  |  |  |  |  |  |  |  |  |  |  |  |  |  |  |  |  |  |  |  |  |  |  |  |  |  |  |  |  |  |  |  |  |  |
| F4550 |  | Site Handover PP-Plant / Start mobilisation | milestone | 0d | 2009-09-03 A | 2009-09-03 A | F2760 (other project) | 100% |  |  |  |  |  | F4550 | 0 | 0 | 934 | 0C | 200 | 001 | C | OWN | L2 | X | 0B | X020 | 0000 | 0 | 0C | X | LND | 0000 |  |  |  |  |  |  |  |  |  |  |  |  |  |
| XC150C0020 |  | Start Piling Works | milestone | 0d | 2009-11-07 A | 2009-11-07 A | XC115502, XC115402, P3C01D (other project) FS+20d, XC150C0010 SS, XC115501, XC115601 | 100% |  |  |  |  |  | XC150C0020 | 0 | 0 | 934 | 0C | 200 | 200 | C | LND | L2 | X | 0B | X030 | 0000 | 0 | 0C | X | LND | 0000 | P |  |  |  |  |  |  |  |  |  |  |  |  |
| X0300092 |  | Temporary Power/Area Lighting (safe access to site/facilities) in service | milestone | 0d | 2010-05-21 A | 2010-05-21 A | F4550 | 100% |  |  |  |  |  | X0300092 | 0 | 0 | 934 | 0C | 200 | 200 | C | OWN | L2 | X | 0B | X030 | 0000 | 0 | 0C | X | OWN | 0000 | ML | 1 |  |  |  |  |  |  |  |  |  |  |  |
| XC200C10 |  | Start Foundation works | milestone | 0d | 2010-05-24 A | 2010-05-24 A | XC200C00 SS, X0300092, P3C02D1 (other project) | 100% |  |  |  |  |  | XC200C10 | 0 | 0 | 934 | 0C | 200 | 200 | C | LND | L2 | X | 0B | X030 | 0000 | 0 | 0C | X | LND | 0000 | CW | 1 |  |  |  |  |  |  |  |  |  |  |  |
| P3D1000 |  | Contract Award General Cargo Contractor delayed !! | milestone | 0d | 2010-07-22 A | 2010-07-22 A | F4550 | 100% |  |  |  |  |  | P3D1000 | 0 | 0 | 934 | 0C | 200 | 200 | C | OWN | L2 | X | 0B | X030 | 0000 | 0 | 0C | X | LND | 0000 | CW |  | D01 | D01 |  |  |  |  |  |  |  |  |  |
| X0300094 |  | Provide Roads/Bridges for safe Heavy Transport from River Port to Constr. Site, delayed | milestone | 0d | 2010-08-14 A | 2010-08-14 A | P3ALL2S (other project) FS-20d | 100% |  |  |  |  |  | X0300094 | 0 | 0 | 934 | 0C | 200 | 200 | C | OWN | L2 | X | 0B | X030 | 0000 | 0 | 0C | X | OWN | 0000 | ML |  |  |  |  |  |  |  |  |  |  |  |  |
| XB000C10 |  | Start Prefabrication Silo's / Blenders | milestone | 0d | 2010-08-24 A | 2010-08-24 A | XB000C00 SS | 100% |  |  |  |  |  | XB000C10 | 0 | 0 | 934 | 0C | 200 | 200 | C | LND | L2 | X | 0B | X030 | 0000 | 0 | 0C | X | LND | 0000 | MI |  |  |  |  |  |  |  |  |  |  |  |  |
| XCC02D2 |  | Start remain. Civil Works 1st Part (Concrete SuperStructures/Precast/etc.) | milestone | 0d | 2010-08-30 A | 2010-08-30 A | XC200C10 | 100% |  |  |  |  |  | XCC02D2 | 0 | 0 | 860 | 0C | 200 | 200 | P | MO04 | 0 | X | 0B |  | 0000 |  |  |  | LND |  | ci | 1 | C02 |  | 400 | DEV |  |  |  |  |  |  |  |
| XR400C10 |  | Availability of Temporary Lay Down Area (On-Site/Off-Site) | milestone | 0d | 2010-09-30 A | 2010-09-30 A | F4550 | 100% |  |  |  |  |  | XR400C10 | 0 | 0 | 934 | 0C | 200 | 200 | C | OWN | L2 | X | 0B | X030 | 0000 | 0 | 0C | X | LND | 0000 | CW | 1 |  |  |  |  |  |  |  |  |  |  |  |
| XB30120120 |  | Ready for Installation Reactors/Soil preparation finished | milestone | 0d | 2010-12-14 A | 2010-12-14 A | XB30120110 SS | 100% |  |  |  |  |  | XB30120120 | 0 | 0 | 934 | 0C | 200 | 200 | C | LND | L2 | X | 0B | X030 | 0000 | 0 | 0C | X | LND | 0000 | HL | 1 |  |  |  |  |  |  |  |  |  |  |  |
| XR400C20 |  | Avaliability of Temporary Prefabrication Shops | milestone | 0d | 2011-01-17 A | 2011-01-17 A | F4550 | 100% |  |  | start on 2011-01-17 |  |  | XR400C20 | 0 | 0 | 934 | 0C | 200 | 200 | C | OWN | L2 | X | 0B | X030 | 0000 | 0 | 0C | X | LND | 0000 | CW | 1 |  |  |  |  |  |  |  |  |  |  |  |
| XR200C10 |  | Start Prefabrication Piping Material | milestone | 0d | 2011-02-01 A | 2011-02-01 A | XR200C00 SS, XR400C10, EL20010 (other project) | 100% |  |  |  |  |  | XR200C10 | 0 | 0 | 934 | 0C | 200 | 200 | C | LND | L2 | X | 0B | X030 | 0000 | 0 | 0C | X | LND | 0000 | MI | 1 |  |  |  |  |  |  |  |  |  |  |  |
| XC20C000 |  | Foundation released for Installation Structural Steel (all Areas) | milestone | 0d | 2011-04-01 A | 2011-04-01 A | EC281232 (other project), EC285104 (other project), EC285402 (other project), EC285503 (other project), EC28120105 (other project), EC285101 (other project), EC285102 (other project), EC28130105 (other project), EC281233 (other project), EC283115 (other project), EC285502 (other project), EC28130110 (other project), EC28311004 (other project), EC285103 (other project), EC285201 (other project), EC28120410 (other project), EC285401 (other project), EC285501 (other project) | 100% |  |  | finish on 2011-03-31 |  |  | XC20C000 | 0 | 0 | 934 | 0C | 200 | 200 | C | LND | L2 | X | 0B | X030 | 0000 | 0 | 0C | X | LND | 0000 | OB | 1 |  |  |  |  |  |  |  |  |  |  |  |
| XB500C10 |  | Ready for Installation Silo's / Blenders | milestone | 0d | 2011-08-24 A | 2011-08-24 A | XB000C10, XB500C00 | 100% |  |  | start on or before 2011-06-15 |  |  | XB500C10 | 0 | 0 | 934 | 0C | 200 | 200 | C | LND | L2 | X | 0B | X030 | 0000 | 0 | 0C | X | LND | 0000 | MI |  |  |  |  |  |  |  |  |  |  |  |  |
| XC300C10 |  | Start UG Precast Fabrication (Manholes) | milestone | 0d | 2011-08-25 A | 2011-08-25 A | XC300C00 | 100% |  |  | as late as possible |  |  | XC300C10 | 0 | 0 | 934 | 0C | 200 | 200 | C | LND | L2 | X | 0B | X030 | 0000 | 0 | 0C | X | LND | 0000 | CW |  |  |  |  |  |  |  |  |  |  |  |  |
| X0300020 |  | IF01 - Supply Service Water (press. test's) | milestone | 0d | 2011-08-31 | 2011-08-31 | YY0100 |  | -17d | 25d | finish on 2011-08-31 |  |  | X0300020 | 0 | 0 | 934 | 0C | 200 | 200 | C | UIO | L2 | X | 0B | X030 | 0000 | 0 | 0C | X | OWN | 0000 | ML |  |  |  |  |  | UDF_G4 |  |  |  |  |  |  |
| X0300025 |  | IF22/.. Waste Water System in service (press. test's) | milestone | 0d | 2011-08-31 | 2011-08-31 | YY0100 |  | -5d | 24d | finish on 2011-08-31 |  |  | X0300025 | 0 | 0 | 934 | 0C | 200 | 200 | C | UIO | L2 | X | 0B | X030 | 0000 | 0 | 0C | X | OWN | 0000 | ML |  |  |  |  |  | UDF_G4 | 2011-06-24 | 2011-06-24 |  |  |  |  |
| X0300075 |  | IF06 Supply Potable Water | milestone | 0d | 2011-08-31 | 2011-08-31 |  |  | 0d | 141d | finish on 2011-08-31 |  |  | X0300075 | 0 | 0 | 934 | 0C | 200 | 200 | C | UIO | L2 | X | 0B | X030 | 0000 | 0 | 0C | X | OWN | 0000 | ML |  |  |  |  |  | UDF_G4 |  |  |  |  |  |  |
| XC001600 |  | CA16 Substation - Bldg cover closed | milestone | 0d | 2011-09-09 | 2011-09-09 | XN801610 FF |  | 140d | 91d |  |  |  | XC001600 | 0 | 0 | 934 | 0C | 200 | 200 | C | LND | L2 | X | 0B | X030 | 0000 | 0 | 0C | X | LND | 0000 | OB |  |  |  |  |  |  |  |  |  |  |  |  |
| X020410050 |  | CA41 Control Bldg - Clearance Rooms by UI&O | milestone | 0d | 2011-09-29 | 2011-09-29 | F4550 |  | -84d | 0d | as late as possible |  |  | X020410050 | 0 | 0 | 934 | 0C | 200 | 200 | C | UIO | L2 | X | 0B | XC50 | 0000 | C | 16 | X | LND | 1610 | IN |  |  |  |  |  |  |  |  |  |  |  |  |
| X0300008 |  | IF02/03 Supply Cooling Water | milestone | 0d | 2011-10-01 | 2011-10-01 | X0300060 FF |  | 143d | 97d |  |  |  | X0300008 | 0 | 0 | 934 | 0C | 200 | 200 | C | UIO | L2 | X | 0B | X030 | 0000 | 0 | 0C | X | OWN | 0000 | ML |  |  |  |  |  |  |  |  |  |  |  |  |
| X0300016 |  | IF11 Supply LP Steam | milestone | 0d | 2011-10-01 | 2011-10-01 |  |  | 0d | 117d | finish on 2011-10-01 |  |  | X0300016 | 0 | 0 | 934 | 0C | 200 | 200 | C | UIO | L2 | X | 0B | X030 | 0000 | 0 | 0C | X | OWN | 0000 | ML |  |  |  |  |  |  | 2011-10-01 | 2011-10-01 |  |  |  |  |
| X0300060 |  | IF23/24 Supply Hot Water (Air Heater HVAC System) | milestone | 0d | 2011-10-01 | 2011-10-01 |  |  | 0d |  | finish on 2011-10-01 |  |  | X0300060 | 0 | 0 | 934 | 0C | 200 | 200 | C | UIO | L2 | X | 0B | X030 | 0000 | 0 | 0C | X | OWN | 0000 | ML |  |  |  |  |  |  | 2011-10-01 | 2011-10-01 |  |  |  |  |
| X0300080 |  | IF28 Condensate system in service | milestone | 0d | 2011-10-01 | 2011-10-01 |  |  | 0d | 117d | finish on 2011-10-01 |  |  | X0300080 | 0 | 0 | 934 | 0C | 200 | 200 | C | UIO | L2 | X | 0B | X030 | 0000 | 0 | 0C | X | OWN | 0000 | ML |  |  |  |  |  |  | 2011-10-01 | 2011-10-01 |  |  |  |  |
| X020410055 |  | PipeRack Control Bldg to PR5501 - Clearance by UI&O | milestone | 0d | 2011-10-01 | 2011-10-01 | F4550 |  | 0d | 204.5d | finish on 2011-10-01 |  |  | X020410055 | 0 | 0 | 934 | 0C | 200 | 200 | C | UIO |  | X | 0B | XC50 | 0000 | C | 16 | X | LND | 1610 | IN | 1 |  |  |  |  |  |  |  |  |  |  |  |
| X0300005 |  | Delivery Power Supply to MV SWG CA41 | milestone | 0d | 2011-11-29 | 2011-11-29 | XE204100 |  | -63d | 0d | start on 2011-09-15 |  |  | X0300005 | 0 | 0 | 934 | 0C | 200 | 200 | C | OWN | L2 | X | 0B | X030 | 0000 | 0 | 0C | X | OWN | 0000 | ML |  |  |  |  |  |  |  |  |  |  |  |  |
| XC001710 |  | CA17 Extrusion Bldg 1st Floor - Bldg cover closed | milestone | 0d | 2011-11-30 | 2011-11-30 | XC40171020 FF, XC40171013 |  | 9.88d | 0d |  |  |  | XC001710 | 0 | 0 | 934 | 0C | 200 | 200 | C | LND | L2 | X | 0B | X030 | 0000 | 0 | 0C | X | LND | 0000 | OB | 1 |  |  |  |  | UDF_G4 |  |  |  |  |  |  |
| XC001322 |  | CA13 Teal Bldg - Bldg cover closed | milestone | 0d | 2011-12-03 | 2011-12-03 | XN801322 FF |  | 76d | 0d |  |  |  | XC001322 | 0 | 0 | 934 | 0C | 200 | 200 | C | LND | L2 | X | 0B | X030 | 0000 | 0 | 0C | X | LND | 0000 | OB |  |  |  |  |  |  |  |  |  |  |  |  |
| X0300030 |  | IF07/08/19/26 Supply MP/HP Firewater | milestone | 0d | 2011-12-07 | 2011-12-07 | XC305103 SF, XC305301 SF, XC301100 SF, XC301200 SF, XC305102 SF, XC301300 SF, XC301700 SF, XC301710 SF, XC305201 SF, XC305402 SF, XC305501 SF, XC301707 SF, XC305401 SF, XC305502 SF, XC305503 SF, XC305601 SF, XC301510 SF, XC301708 SF, XC305101 SF, XC305104 SF |  | -56d | 328.5d | finish on 2011-10-01 |  |  | X0300030 | 0 | 0 | 934 | 0C | 200 | 200 | C | UIO | L2 | X | 0B | X030 | 0000 | 0 | 0C | X | OWN | 0000 | ML |  |  |  |  |  |  | 2011-10-01 | 2011-10-01 |  |  |  |  |
| XB30176020 |  | Ready for Installation Purge Columns/Soil preparation finished | milestone | 0d | 2011-12-20 | 2011-12-20 | XB30141010, XB10176010 SS-1d |  | -36d | 63d |  |  |  | XB30176020 | 0 | 0 | 934 | 0C | 200 | 200 | C | LND | L2 | X | 0B | X030 | 0000 | 0 | 0C | X | LND | 0000 | HL | 1 |  |  |  |  |  |  |  |  |  |  |  |
| XC001222 |  | CA12 Teal Bldg - Bldg cover closed | milestone | 0d | 2011-12-27 | 2011-12-27 | XN801222 FF |  | 19.5d | 0d |  |  |  | XC001222 | 0 | 0 | 934 | 0C | 200 | 200 | C | LND | L2 | X | 0B | X030 | 0000 | 0 | 0C | X | LND | 0000 | OB |  |  |  |  |  |  |  |  |  |  |  |  |
| XC003110 |  | CA31 Silo Structure - Bldg cover closed | milestone | 0d | 2012-01-16 | 2012-01-16 | XN803110S FF, XN803110 FF |  | 38d | 18d |  |  |  | XC003110 | 0 | 0 | 934 | 0C | 200 | 200 | C | LND | L2 | X | 0B | X030 | 0000 | 0 | 0C | X | LND | 0000 | OB | 1 |  |  |  |  |  |  |  |  |  |  |  |
| XC003100 |  | CA31 Warehouse - Bldg cover closed (ready for temp. use) | milestone | 0d | 2012-01-27 | 2012-01-27 | XN803140, XN803140S |  | 85d | 35d |  |  |  | XC003100 | 0 | 0 | 934 | 0C | 200 | 200 | C | LND | L2 | X | 0B | X030 | 0000 | 0 | 0C | X | LND | 0000 | OB | 1 |  |  |  |  |  |  |  |  |  |  |  |
| XC001718 |  | CA17 Extrusion Bldg 2nd Floor - Bldg cover closed | milestone | 0d | 2012-02-15 | 2012-02-15 | XN801718 FF, XC001710 FS+60d |  | 57d | 0d |  |  |  | XC001718 | 0 | 0 | 934 | 0C | 200 | 200 | C | LND | L2 | X | 0B | X030 | 0000 | 0 | 0C | X | LND | 0000 | OB |  |  |  |  |  |  |  |  |  |  |  |  |
| XC003130 |  | CA31 Service Area - Bldg cover closed | milestone | 0d | 2012-02-20 | 2012-02-20 | XN803130 FF |  | -121d | 4d |  |  |  | XC003130 | 0 | 0 | 934 | 0C | 200 | 200 | C | LND | L2 | X | 0B | X030 | 0000 | 0 | 0C | X | LND | 0000 | OB |  |  |  |  |  |  |  |  |  |  |  |  |
| X0300085 |  | IF29 Sanitary Waste Water System in service | milestone | 0d | 2012-02-21 | 2012-02-21 | XC50161010 SF, XC501321 SF, X0300075 FF, XC501710 SF, XC501222 SF, XC501322 SF, XC501221 SF, XC50161020 SF |  | 339.5d |  |  |  |  | X0300085 | 0 | 0 | 934 | 0C | 200 | 200 | C | UIO | L2 | X | 0B | X030 | 0000 | 0 | 0C | X | OWN | 0000 | ML |  |  |  |  |  |  |  |  |  |  |  |  |
| XC003120 |  | CA31 Blower Section - Bldg cover closed | milestone | 0d | 2012-02-22 | 2012-02-22 | XN803120 FF |  | 6d | 5d |  |  |  | XC003120 | 0 | 0 | 934 | 0C | 200 | 200 | C | LND | L2 | X | 0B | X030 | 0000 | 0 | 0C | X | LND | 0000 | OB |  |  |  |  |  |  |  |  |  |  |  |  |
| XC001100 |  | CA11 Compressor Bldg - Bldg cover closed | milestone | 0d | 2012-02-29 | 2012-02-29 | XN801110 FF |  | 71d | 53.5d |  |  |  | XC001100 | 0 | 0 | 934 | 0C | 200 | 200 | C | LND | L2 | X | 0B | X030 | 0000 | 0 | 0C | X | LND | 0000 | OB |  |  |  |  |  |  |  |  |  |  |  |  |
| X0300014 |  | IF10 Supply Plant Air | milestone | 0d | 2012-03-01 | 2012-03-01 | YY0100 FF, XR605402 SF, XR605501 SF, XR601232 SF, XR605104 SF, XR605101 SF, XR605102 SF, XR605601 SF, XR601330 SF, XR601332 SF, XR605401 SF |  | -122d | 20d | finish on 2011-10-01 |  |  | X0300014 | 0 | 0 | 934 | 0C | 200 | 200 | C | UIO | L2 | X | 0B | X030 | 0000 | 0 | 0C | X | OWN | 0000 | ML |  |  |  |  |  |  | 2011-10-01 | 2011-10-01 |  |  |  |  |
| XC001720 |  | CA17 Extrusion Bldg 3rd Floor - Bldg cover closed | milestone | 0d | 2012-03-12 | 2012-03-12 | XN801720 FF, XC001718 FS+20d |  | 57d | 0d |  |  |  | XC001720 | 0 | 0 | 934 | 0C | 200 | 200 | C | LND | L2 | X | 0B | X030 | 0000 | 0 | 0C | X | LND | 0000 | OB |  |  |  |  |  |  |  |  |  |  |  |  |
| XC001321 |  | CA13 Catalyst Bldg - Bldg cover closed | milestone | 0d | 2012-03-16 | 2012-03-16 | XN801321 FF |  | 90d | 100d |  |  |  | XC001321 | 0 | 0 | 934 | 0C | 200 | 200 | C | LND | L2 | X | 0B | X030 | 0000 | 0 | 0C | X | LND | 0000 | OB |  |  |  |  |  |  |  |  |  |  |  |  |
| X0300012 |  | IF25 Supply Raw Nitrogen | milestone | 0d | 2012-04-06 | 2012-04-06 | XR601204 SF, XR605502 SF, XR601322 SF, XR605201 SF, XR601321 SF, X0300014 FF+10d, XR605402 SF, XR601332 SF, XR601232 SF, XR605104 SF, XR605503 SF, XR605101 SF, XR605102 SF, XR601221 SF, XR601233 SF, XR605501 SF, XR601330 SF, XR601111 SF, XR601230 SF-10d, XR605601 SF, XR601304 SF, YY0100 FF |  | 11d | 106.5d |  |  |  | X0300012 | 0 | 0 | 934 | 0C | 200 | 200 | C | UIO | L2 | X | 0B | X030 | 0000 | 0 | 0C | X | OWN | 0000 | ML |  |  |  |  |  |  |  |  |  |  |  |  |
| XC001221 |  | CA12 Catalyst Bldg - Bldg cover closed | milestone | 0d | 2012-04-11 | 2012-04-11 | XN801221 FF |  | 48d | 20d |  |  |  | XC001221 | 0 | 0 | 934 | 0C | 200 | 200 | C | LND | L2 | X | 0B | X030 | 0000 | 0 | 0C | X | LND | 0000 | OB |  |  |  |  |  |  |  |  |  |  |  |  |
| X020314000 |  | CA31 Warehouse - Railyway inside installed by UI&O | milestone | 0d | 2012-05-31 | 2012-05-31 | XC40314015 SF |  | 0d | 257.5d | finish on 2012-05-31 |  |  | X020314000 | 0 | 0 | 934 | 0C | 200 | 200 | C | UIO | L2 | X | 0B | XC50 | 0000 | C | 16 | X | LND | 1610 | IN |  |  |  |  |  |  | 2011-08-26 | 2011-08-26 |  |  |  |  |
| XX0120 |  | Punch out (Linde) | level of effort | 177d | 2012-07-04 | 2012-12-31 | X0101710, X0103110, X0101310, X0101410, X0101110, X0101510, X0101210, X0101010, X0105110 |  | -125.5d | 0d |  | TB26 - 6 - Contract Milest. | Rotating equipment (w/o lube oil unit); Rotating equipment (w/ lube oil unit); Static equipment < 10t; Static equipment >10t; Extruder; Silos; Packaging lines; Propylene recovery unit; Flare; Installation main equipment substation; Cable connecting; Electrical heat tracing; Communication System; Fire detection system; Lighting (iluminates); Field panels; Installation Main Equipment Control Building/RIB; Install Junction Boxes/ Cabinets/ Panels; Termination field; Termination Control Building; Install field instruments; Install Control & Shut-off Valves; Loop checks | XX0120 | 0 | 0 |  | 0C | 200 | 200 | E | LND | L2 | X | 0B | 0000 | 0000 |  |  |  | LND |  | MC |  |  |  | 025 |  |  |  |  | 0,00 | XX0110; XX120 | x |  |
| X0300090 |  | Winterization Measures for Inhouse working (2nd winter) in place | milestone | 0d | 2012-08-25 | 2012-08-25 | XC001720 FS+60d, XH00122207, XH00171011, XH00173007 FS-10d, XH00311007, XH00313007, XE50313015, XH00132107, XH00111007, XH00161006, XH00161008, XH00171008, XH00171807, XH00173607 FS-30d, XH00171010 SF, XH00122107, XH00132207, XH00161011, XH00172007 FS-5d, XH00312007, XH00111006, XH00314007 FS-40d, XC001718 |  | 184d |  |  |  |  | X0300090 | 0 | 0 | 934 | 0C | 200 | 200 | C | LND | L2 | X | 0B | X030 | 0000 | 0 | 0C | X | OWN | 0000 | ML | 1 |  |  |  |  |  |  |  |  | X0300090 |  |  |
| X3J120 |  | DCS Start with Loop Checks | milestone | 0d | 2012-08-25 | 2012-08-25 | XE50161015, XJ801610 SF |  | -107.5d | 0d |  |  |  | X3J120 | 0 | 0 | 934 | 0C | 200 | 001 | C | LND | L2 | X | 0B | X020 | 0000 | 0 | 0C | X | LND | 0000 | LT | 1 |  |  |  |  |  |  |  |  |  |  |  |
| X0300015 |  | IF09/27 Supply Instrument Air (HP) | milestone | 0d | 2012-08-25 | 2012-08-25 | XJ800C00 SF |  | -96.5d | 0d |  |  |  | X0300015 | 0 | 0 | 934 | 0C | 200 | 200 | C | UIO | L2 | X | 0B | X030 | 0000 | 0 | 0C | X | OWN | 0000 | ML |  |  |  |  |  |  |  |  |  |  |  |  |
| XX0100 |  | Construction Completion all Areas | milestone | 0d | 2012-10-20 | 2012-10-20 | X0101110, X0300012 FF+60d, X0101410, X0101510, X0104110, X0105110, X0105410, X0101310, X0101710, A1CF0245 (other project), X0101210, X0105310, X0105610, X0101010, X0103110, X0105210, X0105510 |  | -95.5d | 0d | finish on 2012-07-25 |  |  | XX0100 | 0 | 0 | 934 | 0C | 200 | 200 | C | LND | L2 | X | 0B | X010 | 0000 | 0 | 0C | X | LND | 0000 | MC | 1 |  |  |  |  |  |  |  |  | HE00125 |  |  |
| XX0110 |  | PP Construction finished all Areas (LINDE) | milestone | 0d | 2012-10-20 | 2012-10-20 | X0101110, X0101410, X0104110, X0105610, X0105410, X0101210, X0101510, X0101310, X0101710, X0103110, X0105310, X0101010, X0105110, X0105210, X0105510 |  | 160d |  |  | TB26 - 6 - Contract Milest. |  | XX0110 | 0 | 0 |  | 0C | 200 | 200 | E | LND | L2 | X | 0B | 0000 | 0000 |  |  |  | LND |  | MC |  |  |  | 025 |  |  |  |  |  |  | x |  |
| X0300035 |  | IF12 Supply Demineralized Water | milestone | 0d | 2012-12-31 | 2012-12-31 | IMS-LND-MC-00010 (other project) |  | 20d | 5.5d |  |  |  | X0300035 | 0 | 0 | 934 | 0C | 200 | 200 | C | UIO | L2 | X | 0B | X030 | 0000 | 0 | 0C | X | OWN | 0000 | ML |  |  |  |  |  |  |  |  |  |  |  |  |
| X0300040 |  | IF13/14 Supply EW/SS Water | milestone | 0d | 2012-12-31 | 2012-12-31 | IMS-LND-MC-00010 (other project) |  | 23d | 8d |  |  |  | X0300040 | 0 | 0 | 934 | 0C | 200 | 200 | C | UIO | L2 | X | 0B | X030 | 0000 | 0 | 0C | X | OWN | 0000 | ML |  |  |  |  |  |  |  |  |  |  |  |  |
| X0300045 |  | IF15 Supply Purified Hydrogen | milestone | 0d | 2012-12-31 | 2012-12-31 | IMS-LND-MC-00010 (other project) |  | 66d | 30d |  |  |  | X0300045 | 0 | 0 | 934 | 0C | 200 | 200 | C | UIO | L2 | X | 0B | X030 | 0000 | 0 | 0C | X | OWN | 0000 | ML |  |  |  |  |  |  |  |  |  |  |  |  |
| X0300050 |  | IF16/18 Supply Propylene | milestone | 0d | 2012-12-31 | 2012-12-31 | IMS-LND-MC-00010 (other project) |  | 66d | 30d |  |  |  | X0300050 | 0 | 0 | 934 | 0C | 200 | 200 | C | UIO | L2 | X | 0B | X030 | 0000 | 0 | 0C | X | OWN | 0000 | ML |  |  |  |  |  |  |  |  |  |  |  |  |
| X0300055 |  | IF20 Supply Natural Gas | milestone | 0d | 2012-12-31 | 2012-12-31 | IMS-LND-MC-00010 (other project) |  | 60d | 24d |  |  |  | X0300055 | 0 | 0 | 934 | 0C | 200 | 200 | C | UIO | L2 | X | 0B | X030 | 0000 | 0 | 0C | X | OWN | 0000 | ML |  |  |  |  |  |  |  |  |  |  |  |  |
| X0300065 |  | IF05 Supply Purified Nitrogen | milestone | 0d | 2012-12-31 | 2012-12-31 | IMS-LND-MC-00010 (other project) |  | 17.5d | 3d |  |  |  | X0300065 | 0 | 0 | 934 | 0C | 200 | 200 | C | UIO | L2 | X | 0B | X030 | 0000 | 0 | 0C | X | OWN | 0000 | ML |  |  |  |  |  |  |  |  |  |  |  |  |
| X0300070 |  | IF04 Supply HP Nitrogen | milestone | 0d | 2012-12-31 | 2012-12-31 | IMS-LND-MC-00010 (other project) |  | 17.5d | 3d |  |  |  | X0300070 | 0 | 0 | 934 | 0C | 200 | 200 | C | UIO | L2 | X | 0B | X030 | 0000 | 0 | 0C | X | OWN | 0000 | ML |  |  |  |  |  |  |  |  |  |  |  |  |
| XX120 |  | Mechanical Completion all Areas | milestone | 0d | 2012-12-31 | 2012-12-31 | X0105400, X0101100, X0051700 FF, X0101400, X0105600, X0101000, XX0120 FF, X0101600, X0101700, X0105100, X0105500, X0101300, X0101500, X0103100, X0104100, X0105300, X0101200, X0105200 |  | -106.5d | 0d | finish on 2012-08-24 |  |  | XX120 | 0 | 0 | 934 | 0C | 200 | 200 | C | LND | L2 | X | 0B | X010 | 0000 | 0 | 0C | X | LND | 0000 | MC | 1 |  |  |  |  |  |  |  |  | XX120 |  | MTA |

Notes:
- F4550: UDF_Actictity Name (Russia): Передача площадки, Установка ПП / Начало мобилизации
- XC150C0020: UDF_Actictity Name (Russia): Начало сваезабивных работ
- X0300092: UDF_Actictity Name (Russia): CA00 Общее - Подача электропитания
- XC200C10: UDF_Actictity Name (Russia): Начало общестроительных работ
- P3D1000: UDF_Actictity Name (Russia): Начало монтажа подземных сооружений
- X0300094: P3 Activity Log Info: no / limitation by existing pipe racks / UDF_Actictity Name (Russia): CA00 Общее - Подача электропитания
- XB000C10: UDF_Actictity Name (Russia): Начало изготовления силосов / гомогенизаторов
- XR400C10: UDF_Actictity Name (Russia): Начало монтажа подземных сооружений
- XB30120120: UDF_Actictity Name (Russia): Готовность к монтажу реакторов
- XR400C20: UDF_Actictity Name (Russia): Начало монтажа подземных сооружений
- XR200C10: UDF_Actictity Name (Russia): Начало изготовления трубопроводов
- XC20C000: UDF_Actictity Name (Russia): CA31 Участок подготовки и отгрузки продукта - Готовность к временному использованию
- XB500C10: UDF_Actictity Name (Russia): Готовность к монтажу силосов / гомогенизаторов
- XC300C10: UDF_Actictity Name (Russia): Начало монтажа подземных сооружений
- X0300020: UDF_Actictity Name (Russia): CA00 Общее - Подача технической воды / Comments: Clarifications w Chris Knop: 30.04.11 ?? Water Truck??
- X0300025: UDF_Actictity Name (Russia): CA00 Общее - Ввод в действие системы сточных вод / Comments: Clarifications w Chris Knop: 23.06.11 ?? Waste water truck??
- X0300075: Scope: trinkwasser muss ca. 20 Tage VOR Beginn der HVAC-Test zur / Verfьgung stehen. / UDF_Actictity Name (Russia): CA00 Общее - Подача воздуха КИП
- XC001600: UDF_Actictity Name (Russia): CA31 Участок подготовки и отгрузки продукта - Готовность к временному использованию
- X020410050: Comments: Clarifications w Chris Knop: 30.04.11 ??
- X0300008: UDF_Actictity Name (Russia): CA00 Общее - Подача пара для ОВКВ / Comments: Clarifications w Chris Knop: 25.10.11 ??
- X0300016: Current Status: 110131 Delete Predecessor XH000C10 CA00 General - Start / Testing/Commissioning HVAC / UDF_Actictity Name (Russia): CA00 Общее - Подача технологического воздуха / Comments: Clarifications w Chris Knop: 07.10.11 ??
- X0300060: Current Status: 110131 Delete Predecessor XH000C10 CA00 General - Start / Testing/Commissioning HVAC / UDF_Actictity Name (Russia): CA00 Общее - Подача воздуха КИП / Comments: Clarifications w Chris Knop: 07.10.11 ??
- X0300080: Current Status: 110131 Delete Predecessor XH000C10 CA00 General - Start / Testing/Commissioning HVAC / UDF_Actictity Name (Russia): CA00 Общее - Подача воздуха КИП / Comments: Clarifications w Chris Knop: 07.10.11 ??
- X020410055: Comments: Clarifications w Chris Knop: What does it actually mean??
- X0300005: UDF_Actictity Name (Russia): CA00 Общее - Подача электропитания
- XC001710: UDF_Actictity Name (Russia): CA31 Участок подготовки и отгрузки продукта - Готовность к временному использованию
- XC001322: UDF_Actictity Name (Russia): CA31 Участок подготовки и отгрузки продукта - Готовность к временному использованию
- X0300030: UDF_Actictity Name (Russia): CA00 Общее - Подача воздуха КИП / Comments: Clarifications w Chris Knop: 05.01.12 ?? Fire truck as substitute ??
- XB30176020: UDF_Actictity Name (Russia): Готовность к монтажу реакторов
- XC001222: UDF_Actictity Name (Russia): CA31 Участок подготовки и отгрузки продукта - Готовность к временному использованию
- XC003110: UDF_Actictity Name (Russia): CA31 Участок подготовки и отгрузки продукта - Готовность к временному использованию
- XC003100: UDF_Actictity Name (Russia): CA31 Участок подготовки и отгрузки продукта - Готовность к временному использованию
- XC001718: UDF_Actictity Name (Russia): CA31 Участок подготовки и отгрузки продукта - Готовность к временному использованию
- XC003130: UDF_Actictity Name (Russia): CA31 Участок подготовки и отгрузки продукта - Готовность к временному использованию
- X0300085: UDF_Actictity Name (Russia): CA00 Общее - Подача воздуха КИП
- XC003120: UDF_Actictity Name (Russia): CA31 Участок подготовки и отгрузки продукта - Готовность к временному использованию
- XC001100: UDF_Actictity Name (Russia): CA31 Участок подготовки и отгрузки продукта - Готовность к временному использованию
- X0300014: UDF_Actictity Name (Russia): CA00 Общее - Подача технологического воздуха
- XC001720: UDF_Actictity Name (Russia): CA31 Участок подготовки и отгрузки продукта - Готовность к временному использованию
- XC001321: UDF_Actictity Name (Russia): CA31 Участок подготовки и отгрузки продукта - Готовность к временному использованию
- X0300012: UDF_Actictity Name (Russia): CA00 Общее - Подача азота
- XC001221: UDF_Actictity Name (Russia): CA31 Участок подготовки и отгрузки продукта - Готовность к временному использованию
- X020314000: Comments: Clarifications w Chris Knop: 31.07.11 ??
- XX0120: UDF_Actictity Name (Russia): Завершение механических работ на всех участках ПП (обязательно)
- X0300090: UDF_Actictity Name (Russia): CA00 Общее - Подача воздуха КИП / Comments: Clarifications w Chris Knop: UIO responsibility ??
- X3J120: UDF_Actictity Name (Russia): Готовность РСУ к проверке контуров
- X0300015: UDF_Actictity Name (Russia): CA00 Общее - Подача воздуха КИП
- XX0100: Objectives: From: Chris Knop/HA/Contr/FluorCorp / To: / karlheinz.werrel@linde-kca.com / Cc: Lubomir.Jancik@Linde-LE.com, / michael.bollmann@fluor.com, / Timothy / Dolan/HA/Contr/FluorCorp@FluorCorp, / EvstafievDV@sibur.ru, Olivier Boisard / <boisardO@sibur.ru, > / Date: 02/23/2011 12:51 PM / Subject: Baseline / Schedule Proposal for Reporting Purpose - Baseline / Progress / curve / Hello Karlheinz / Just to follow our phone conversation up / with an email to clarify / The Milestone that needs to be added is / construction completion. / The Definition on this project for Construction / Completion is all / installled quantities complete before the generation of a / punchlist / The Mechanical completion Milestone definition is as per industry / standard / eg Construction punch list completed,All A & B Punch / items / completed,Testing and reinstatement complete inclusive of loop / checks. / Please see the attachment of the negative float we discussed and / discuss it / with your people in engineering and procurement to see what the / impact is / to construction. / The final outcome then needs to have one month / float added to each / discipline before the construction completion milestone / (This float belongs / to Linde) / In addition you need to add a single / activity called project float with a 2 / months duration after the mechanical / completion milestone (This float / belongs to the project) / The baseline / progress curve needs to be at maximum of 4% progress per month / with the / exception of the summer months where 4.5 to 5% progress is OK / The one / restriction is that construction completion cannot be later than / August / 2012 / Please apply these principles and see where you end up and let / us / discuss ,this will enable a robust baseline which enables us to manage / the / project / Regards / Chris Knop / UDF_Actictity Name (Russia): Завершение механических работ на всех участках ПП (раньше)
- XX0110: UDF_Actictity Name (Russia): Завершение механических работ на всех участках ПП (обязательно)
- X0300035: UDF_Actictity Name (Russia): CA00 Общее - Подача воздуха КИП
- X0300040: UDF_Actictity Name (Russia): CA00 Общее - Подача воздуха КИП
- X0300045: UDF_Actictity Name (Russia): CA00 Общее - Подача воздуха КИП
- X0300050: UDF_Actictity Name (Russia): CA00 Общее - Подача воздуха КИП
- X0300055: UDF_Actictity Name (Russia): CA00 Общее - Подача воздуха КИП
- X0300065: UDF_Actictity Name (Russia): CA00 Общее - Подача воздуха КИП
- X0300070: UDF_Actictity Name (Russia): CA00 Общее - Подача воздуха КИП
- XX120: Current Status: 24.08.12 Finish On / Constraint acc. Rebaseline May 2011 / UDF_Actictity Name (Russia): Завершение механических работ на всех участках ПП (раньше) / Comments: Set Constraint 24.08.12 acc Rebaseline

| ID | WBS | Activity | Type | Duration | Start | Finish | Predecessors | Complete | Remaining | Planned start | Planned finish | Total float | Free float | Constraint | Calendar | UDF_Actictity Name (Russia) | UDF_SAVE ACT ID | UDF_BUDGETED LABOR UNIT | UDF_ACTUAL LABOR UNIT | Department | Constr. Area | Pro Unit/DocCode | PMT-Area | PMT-Schedule Org | PMT-Phase | PMT-Respons. | Zeigen/n. Zeigen | WBS Phase | WBS Discipline | WBS Type of Work | WBS Objects | Russia WBS Discipline (Russia) | Russia Construction Area | Russia WBS Phase | IMS | UPT | TB26 Ressource Budget | UDF_CONTRACT INDICATOR | Russia WBS Objects | Subcontractor |
| --- | --- | --- | --- | --- | --- | --- | --- | --- | --- | --- | --- | --- | --- | --- | --- | --- | --- | --- | --- | --- | --- | --- | --- | --- | --- | --- | --- | --- | --- | --- | --- | --- | --- | --- | --- | --- | --- | --- | --- | --- |
|  | C | **Civil Work** |  |  | 2009-08-01 | 2012-07-24 |  |  |  |  |  |  |  |  |  |  |  |  |  |  |  |  |  |  |  |  |  |  |  |  |  |  |  |  |  |  |  |  |  |  |
| F4870 |  | Site Prep./Leveling (incl. Dewatering) | level of effort | 52d | 2009-08-01 A | 2009-09-30 A | XC115601 FF, XC113100 FF, XC111600 FF, XC115102 FF, XC111100 FF, XC111100 SS, XC111200 FF, XC111300 FF, XC111700 FF, XC115101 FF | 100% |  |  |  |  |  |  |  | Подготовка площадки/планировка (включая осушение) | F4870 | 0 | 0 | 934 | 00 | 91 | 200 | 200 | C | UIO | M1 | X | C | XC00 | LUTZ | C | 00 | X | C | LND |  |  |  |  |
| F2910 |  | CA00 General - Site mob Piling Contract PP-Plant |  | 32d | 2009-09-03 A | 2009-10-09 A | F4550 SS | 100% |  |  |  |  |  |  |  |  | F2910 | 0 | 0 | 934 | 00 | 91 | 200 | 200 | C | LND |  | X | C | XC00 | LUTZ | C | 00 | X | C | LND |  |  |  |  |
| IMS-C-000010 |  | Excavation/Piling Works | level of effort | 471d | 2009-11-07 A | 2011-05-25 A | XC150C0010 SS | 100% |  |  |  |  |  |  |  | Выемка грунта/сваезабивные работы | IMS-C-000010 | 0 | 0 | 934 | 00 | 91 | 200 | 200 | C | MO01 | M1 | X | C | XC15 | LUTZ | C | 00 | X | P | IMS | 14169 |  |  |  |
| IMS-C-000230 |  | Earthing Works | level of effort | 348d | 2010-05-24 A | 2011-07-18 A | XC911201 SS, XC913130 SS, XC911111 SS, XC915101 SS, XC913110 SS | 100% |  |  |  |  |  |  |  | Монтаж подстанции | IMS-C-000230 | 0 | 0 | 934 | 00 | 91 | 200 | 200 | C | MO01 |  | X | C | XC00 | LUTZ | E | 00 | X | EA | IMS |  | UDF_G4 |  |  |
| X3C110 |  | Civil / Concrete Works | level of effort | 526.88d | 2010-05-24 A | 2012-02-20 | XC200C00 SS |  | 144.88d |  |  | -2.88d | 0d |  |  | Общестроительные / бетонные работы | X3C110 | 0 | 0 | 934 | 00 | 91 | 200 | 200 | C | LND | M1 | X | C | XC00 | LUTZ | C | 00 | X | CW | LND |  | UDF_G4 |  |  |
| F2860 |  | CA31 Silo Str. Concrete Works Fdtn +Structure | level of effort | 341d | 2010-05-31 A | 2011-07-15 A | XC20311005 SS | 100% |  | 2010-05-31 | 2011-07-16 |  |  |  |  |  | F2860 | 0 | 0 | 934 | 00 | 90 | 200 | 200 | C | LND |  | X | C | XC00 | LUTZ | C | 00 | X | CW | LND |  |  |  |  |
| IMS-C-000050 |  | Equipment & Structures Foundations (Main) | level of effort | 474d | 2010-05-31 A | 2011-12-20 | XC20111005 SS, XC20311005 SS, XC20111010 SS, XC20120105 SS |  | 98d |  |  | 386.5d | 0d |  |  | Монтаж подстанции | IMS-C-000050 | 0 | 0 | 934 | 00 | 91 | 200 | 200 | C | FoW |  | X | C | XC00 | LUTZ | E | 00 | X | mai | IMS |  | UDF_G4 |  |  |
| IMS-C-000110 |  | Other Buildings (CA11/12/13) Erection (Concrete Works) | level of effort | 481d | 2010-05-31 A | 2011-12-28 | XC403130 SS, XC20311005 SS |  | 105d |  |  | -6d | 0d |  |  | Монтаж подстанции | IMS-C-000110 | 0 | 0 | 934 | 00 | 91 | 200 | 200 | C | CiC |  | X | C | XC00 | LUTZ | E | 00 | X | OB | IMS |  | UDF_G4 |  |  |
| IMS-C-000030 |  | PR Foundations, Precasted Elem., Backfilling (Main) | level of effort | 368d | 2010-07-07 A | 2011-02-25 A | XC205102 SS, XC205104 SS, XC205101 SS, XC205103 SS | 100% |  | 2010-07-07 | 2011-09-23 |  |  |  |  | Монтаж подстанции | IMS-C-000030 | 0 | 0 | 934 | 00 | 91 | 200 | 200 | C | LND |  | X | C | XC00 | LUTZ | E | 00 | X | mai | IMS |  |  |  |  |
| IMS-C-000100 |  | Substation Erection (Finish Works) | level of effort | 437d | 2010-07-12 A | 2011-12-26 | XC40161005 SS |  | 103d | 2010-07-12 | 2011-12-19 | 49d | 0d |  |  | Монтаж подстанции | IMS-C-000100 | 0 | 0 | 934 | 00 | 91 | 200 | 200 | C | CiC | M1 | X | C | XC00 | LUTZ | E | 00 | X | SS | IMS |  | UDF_G4 |  |  |
| IMS-C-000080 |  | Extruder Building Erection (Finish Works) | level of effort | 497d | 2010-08-03 A | 2012-04-07 | XC20171005 SS |  | 184d | 2010-08-03 | 2012-03-29 | 34d | 0d |  |  | Монтаж подстанции | IMS-C-000080 | 0 | 0 | 934 | 00 | 91 | 200 | 200 | C | CiC |  | X | C | XC00 | LUTZ | E | 00 | X | EB | IMS |  | UDF_G4 |  |  |
| IMS-C-000020 |  | Precast Concrete Elements | level of effort | 365d | 2010-09-16 A | 2011-12-24 | XC40171805 SS, XC40111005 SS, XC40161010 SS, XC40314010 SS |  | 102d | 2010-09-16 | 2011-12-01 | 17.38d | 0d |  |  | Монтаж подстанции | IMS-C-000020 | 0 | 0 | 934 | 00 | 91 | 200 | 200 | C | CiC |  | X | C | XC00 | LUTZ | E | 00 | X | pre | IMS |  | UDF_G4 |  |  |
| IMS-C-000040 |  | PR Foundations, Precasted Elem., Backfilling (Misc.) | level of effort | 397d | 2010-10-30 A | 2012-02-29 | XC205201 SS, XC205301 SS, XC205402 SS |  | 152d |  |  | 128d | 0d |  |  | Монтаж подстанции | IMS-C-000040 | 0 | 0 | 934 | 00 | 91 | 200 | 200 | C | LND |  | X | C | XC00 | LUTZ | E | 00 | X | mis | IMS |  | UDF_G4 |  |  |
| XC500000 |  | CA00 General - Finishing Works Buildings (incl. Sanitary) | level of effort | 273d | 2011-08-27 | 2012-07-24 | XC500C00 SS, XC510C00 FS+15d |  |  |  |  | 27d | 0d |  |  |  | XC500000 | 0 | 0 | 934 | 00 |  | 200 | 200 | C | CiC |  | X | C | XC50 | LUTZ | C | 0C | X | C | LND |  | UDF_G4 | 0000 |  |
| IMS-C-000070 |  | Underground Precast, Installations & Backfilling | level of effort | 149d | 2011-09-05 | 2012-03-05 | XC301600 SS, XC305201 SS, XC303130 SS, XC301707 SS-5d, XC305101 SS, XC191300 FF |  |  |  |  | 57d | 0d |  |  | Подземные установки | IMS-C-000070 | 0 | 0 | 934 | 00 | 91 | 200 | 200 | C | CiC | M1 | X | C | XC00 | LUTZ | C | 00 | X | UG | IMS |  |  |  |  |
| IMS-C-000135 |  | Fire Proofing - Start Fire Proofing | milestone | 0d | 2011-09-05 | 2011-09-05 |  |  |  |  |  | 82d | 0d | start on or after 2011-09-05 | TB26 - T - Construct-Winter-3 (Dec/Jan/Feb free) * | Подземные установки | IMS-C-000130 | 0 | 0 |  | 00 |  |  |  |  |  |  | X | C | XC80 | LUTZ |  |  |  |  |  |  |  |  | KRILAK |
| IMS-C-000130 |  | Fire Proofing | level of effort | 157d | 2011-09-12 | 2012-06-30 | XC801736 FF |  |  |  |  | 47d | 0d |  | TB26 - T - Construct-Winter-3 (Dec/Jan/Feb free) * | Подземные установки | IMS-C-000130 | 0 | 0 |  | 00 |  |  |  |  |  |  | X | C | XC80 | LUTZ |  |  |  | FP | IMS |  |  |  | KRILAK |
| IMS-C-000120 |  | Paving/ Areas | level of effort | 220d | 2011-09-17 | 2012-06-13 | XC601010 FF, XC603110 SS, XC601600 SS, XC605101 SS |  |  |  |  | 62d | 0d |  |  | Подземные установки | IMS-C-000120 | 0 | 0 |  | 00 |  |  |  |  | CiC |  | X | C | XC60 | LUTZ |  |  |  | PV | IMS |  |  |  |  |
| IMS-C-000060 |  | Equipment & Structures Foundations (Miscellaneous) | level of effort | 135d | 2011-11-03 | 2012-04-18 | XC201602 SS, XC203120 SS |  |  |  |  | -70d | 0d |  |  | Монтаж подстанции | IMS-C-000060 | 0 | 0 | 934 | 00 | 91 | 200 | 200 | C | FoW |  | X | C | XC00 | LUTZ | E | 00 | X | mis | IMS |  |  |  |  |
| IMS-C-000125 |  | Roadways |  | 51d | 2012-03-01 | 2012-04-30 |  |  |  |  |  | 281.5d |  | start on or after 2012-03-01 |  | Подземные установки | IMS-C-000125 | 0 | 0 |  | 00 |  |  |  |  | CiC |  | X | C | XC60 | LUTZ |  |  |  | PV | IMS |  |  |  |  |
| IMS-C-000090 |  | Extruder Building - Entrance Hall (Finish Works) | level of effort | 38d | 2012-06-09 | 2012-07-24 |  |  |  |  |  | 27d | 0d |  |  | Монтаж подстанции | IMS-C-000090 | 0 | 0 | 934 | 00 | 91 | 200 | 200 | C | CiC |  | X | C | XC00 | LUTZ | E | 00 | X | EB | IMS |  |  |  |  |
|  | N | **Structural Steel** |  |  | 2010-12-01 | 2012-05-11 |  |  |  |  |  |  |  |  |  |  |  |  |  |  |  |  |  |  |  |  |  |  |  |  |  |  |  |  |  |  |  |  |  |  |
| IMS-P-000080 |  | Main (Primary) Steel Structure - at Site | level of effort | 150d | 2010-12-01 A | 2011-07-22 A | P3N02#N (other project), P3N01IN (other project), P3N02ZN (other project), P3N01AN (other project), P3N02DN (other project), P3N02ДN (other project), P3N01BN (other project), P3N02BN (other project), P3N02UN (other project), P3N02NN (other project), P3N02YN (other project) FS-1d | 100% |  |  |  |  |  |  | TB26 - V - Construct-Winter partly * | Монтаж общеупотребительной стали и стали узкого применения | IMS-P-000080 | 0 | 0 |  | 00 | 91 | 200 | 200 | C | LND | M1 | X | N | XN00 | LUTZ | N | 00 | X | M | IMS |  | UDF_G4 |  |  |
| IMS-P-000090 |  | Secondary Steel Structure - at Site | level of effort | 106d | 2011-03-11 A | 2011-07-19 A | P3N02AN (other project), P3N02MN (other project), P3N02ДN (other project) | 100% |  |  |  |  |  |  | TB26 - V - Construct-Winter partly * | Монтаж общеупотребительной стали и стали узкого применения | IMS-P-000090 | 0 | 0 | 934 | 00 | 91 | 200 | 200 | C | LND |  | X | N | XN00 | LUTZ | N | 00 | X | M | IMS |  | UDF_G4 |  |  |
| IMS-C-000140 |  | Install Piperack Steel Structure | level of effort | 248d | 2011-04-09 A | 2012-03-30 | XN205101l SS |  | 131d |  |  | -38d | 0d |  | TB26 - V - Construct-Winter partly * | Монтаж общеупотребительной стали и стали узкого применения | IMS-C-000140 | 0 | 0 |  | 00 |  |  |  |  |  |  | X | N | XN20 | LUTZ |  |  |  | PR | IMS |  | UDF_G4 |  |  |
| IMS-C-000150 |  | Installation Primary & Secondary Steel | level of effort | 320d | 2011-04-25 A | 2012-05-11 | XN201110 SS, XN203110 SS, XN201710 SS |  | 164d | 2011-04-25 | 2012-07-12 | 274.5d | 0d |  | TB26 - V - Construct-Winter partly * | Монтаж общеупотребительной стали и стали узкого применения | IMS-C-000150 | 0 | 0 | 934 | 00 | 91 | 200 | 200 | C | LND | M1 | X | N | XN00 | LUTZ | N | 00 | X | SS | IMS |  | UDF_G4 |  |  |

| ID | WBS | Activity | Type | Duration | Start | Finish | Predecessors | Complete | Remaining | Planned start | Planned finish | Total float | Free float | Calendar | Resources | Cost | Actual cost | UDF_CONTRACT INDICATOR | UDF_L3 START DATE | UDF_L3 FINISH DATE | UDF_SAVE ACT ID | UDF_BUDGETED LABOR UNIT | UDF_ACTUAL LABOR UNIT | Department | Constr. Area | PMT-Area | PMT-Schedule Org | PMT-Phase | PMT-Respons. | WBS Phase | WBS Discipline | WBS Type of Work | WBS Objects | Russia WBS Discipline (Russia) | Russia Construction Area | Russia WBS Phase | IMS | UPT | Russia WBS Objects | Pro Unit/DocCode | UDF_Actictity Name (Russia) | Zeigen/n. Zeigen | Type of Work | TB26 Ressource Budget | UDF_Weight (ton) | WEIGHT | UDF_LEVEL | UDF_TAG No | UDF_Object No | UDF_PACKAGE | Subcontractor | UDF_CHECK BASELINE | UDF_DELIVERY DATE PO | UDF_DELIVERY DATE DISPATCH PLANNED | UDF_DELIVERY DATE TO SITE PLANNED | UDF_DELIVERY DATE SITE NEED DATE | POSITION |
| --- | --- | --- | --- | --- | --- | --- | --- | --- | --- | --- | --- | --- | --- | --- | --- | --- | --- | --- | --- | --- | --- | --- | --- | --- | --- | --- | --- | --- | --- | --- | --- | --- | --- | --- | --- | --- | --- | --- | --- | --- | --- | --- | --- | --- | --- | --- | --- | --- | --- | --- | --- | --- | --- | --- | --- | --- | --- |
|  | H | **HVAC** |  |  | 2011-04-17 | 2012-06-29 |  |  |  |  |  |  |  |  |  |  |  |  |  |  |  |  |  |  |  |  |  |  |  |  |  |  |  |  |  |  |  |  |  |  |  |  |  |  |  |  |  |  |  |  |  |  |  |  |  |  |  |
| IMS-P-000100 |  | HVAC - Goods/Material delivery at Site | level of effort | 385d | 2011-04-17 A | 2012-06-06 | P3H01SA (other project) |  | 233d | 2011-04-18 | 2012-07-26 | 251.5d | 0d |  |  |  |  | UDF_G4 | 2011-01-24 | 2011-10-21 | IMS-P-000100 | 0 | 0 | 934 | 00 | 200 | 200 | C | LND | X | H | XH00 | LUTZ | H | 0C | X | hva_as | IMS | 0000 |  |  |  |  |  |  |  |  |  |  |  |  |  |  |  |  |  |  |
| XH000000 |  | CA00 General - Installation HVAC | level of effort | 380d | 2011-04-23 A | 2012-06-27 | XH000C00 SS, X0300080 FF+10d |  | 250d | 2011-04-23 | 2012-07-26 | 234.5d | 0d |  |  |  |  | UDF_G4 | 2011-03-17 | 2011-10-26 | XH000000 | 0 | 0 | 934 | 00 | 200 | 200 | C | LND | X | H | XH00 | LUTZ | H | 0C | X | hvac | LND | 0000 |  |  |  |  |  |  |  |  |  |  |  |  |  |  |  |  |  |  |
| XH000010 |  | CA00 General - Testing/Commissioning HVAC (Start w. temp. Power) | level of effort | 105d | 2012-02-24 | 2012-06-29 | XH00311010 SS, XH00132110 SS, XH00111010 SS, XH00122110 SS, XH00161010 SS, XH00313010 SS |  |  |  |  | 48d | 0d |  |  |  |  |  | 2011-07-13 | 2011-12-19 | XH000010 | 0 | 0 | 934 | 00 | 200 | 200 | C | LND | X | H | XH20 | LUTZ | H | 0C | X | hvac | LND | 0000 |  |  |  |  |  |  |  |  |  |  |  |  |  |  |  |  |  |  |
|  | U | **Package Units** |  |  |  |  |  |  |  |  |  |  |  |  |  |  |  |  |  |  |  |  |  |  |  |  |  |  |  |  |  |  |  |  |  |  |  |  |  |  |  |  |  |  |  |  |  |  |  |  |  |  |  |  |  |  |  |
|  | B | **Mechanical - Stationary Equipment** |  |  | 2010-08-23 | 2012-05-04 |  |  |  |  |  |  |  |  |  |  |  |  |  |  |  |  |  |  |  |  |  |  |  |  |  |  |  |  |  |  |  |  |  |  |  |  |  |  |  |  |  |  |  |  |  |  |  |  |  |  |  |
| IMS-P-000020 |  | LL Equipment - Delivery at Site | level of effort | 285d | 2010-08-23 A | 2011-10-14 | P3ALL4S1 (other project), P3M02S1 (other project) |  | 42d | 2010-08-23 | 2011-09-28 | -88d | 0d | TB26 - V - Construct-Winter partly * |  |  |  | UDF_G4 | 2010-08-23 | 2011-09-03 | IMS-P-000020 | 0 | 0 | 934 | 00 | 200 | 200 | C | LND | X | B | XB00 | LUTZ | B | 00 | X | S | IMS |  | 90 |  |  |  |  |  |  |  |  |  |  |  |  |  |  |  |  |  |
| F2870 |  | CA31 Silo Struc - Silo fab and erection on site | level of effort | 263d | 2010-08-24 A | 2011-09-30 | XB50311005 SS |  | 30d | 2010-08-24 | 2011-09-03 | -116d | 0d | TB26 - V - Construct-Winter partly * |  |  |  | UDF_G4 | 2010-08-24 | 2011-05-14 | F2870 | 0 | 0 | 934 | 00 | 200 | 200 | C | LND | X | B | XB00 | LUTZ | B | 00 | X | C | LND |  | 90 |  |  |  |  |  |  |  |  |  |  |  |  |  |  |  |  |  |
| IMS-P-000050 |  | DCE - Delivery at Site | level of effort | 195d | 2010-11-25 A | 2011-09-24 | P3M06S1 (other project), P3M05S1 (other project), P3U02S1 (other project), P3A07S1 (other project) |  | 25d | 2010-11-29 | 2011-09-10 | 36d | 0d | TB26 - V - Construct-Winter partly * |  |  |  | UDF_G4 | 2010-11-25 | 2011-04-05 | IMS-P-000050 | 0 | 0 | 934 | 00 | 200 | 200 | C | LND | X | B | XB00 | LUTZ | B | 00 | X | S | IMS |  | 90 |  |  |  |  |  |  |  |  |  |  |  |  |  |  |  |  |  |
| IMS-P-000070 |  | Other Equipment - Delivery at Site | level of effort | 190d | 2010-11-30 A | 2011-08-30 | P3A13S1A (other project), P3M07S1 (other project), P3M10S1 (other project), P3A06S1 (other project) | 100% | 3d | 2010-12-01 | 2011-09-07 | 0d |  | TB26 - V - Construct-Winter partly * |  |  |  | UDF_G4 | 2010-11-30 | 2011-04-29 | IMS-P-000070 | 0 | 0 | 934 | 00 | 200 | 200 | C | LND | X | B | XB00 | LUTZ | B | 00 | X | S | IMS |  | 90 |  |  |  |  |  |  |  |  |  |  |  |  |  |  |  |  |  |
| IMS-C-000165 |  | Installation Mechanical Equipment | level of effort | 290d | 2011-05-26 A | 2012-05-04 | HO-21202, XB500C00 SS, PK-21211 SS, CY-22202, AG-22201, C-21801 SS, MI-21801 SS, V-21221 SS, HO-21203, PK-22211, E-22206, V-22222 (other project), V-22221, HO-21204, E-21203 SS, MI-21202 SS, V-21224 SS, HO-22203, HO-22201, AG-21201 SS, V-21223 SS, HO-22204, HO-22202, V-22224, E-21206 SS, V-21222 SS, MI-22202, HO-21201, CY-21202 SS, HO-21210, V-22223 SS, E-22203 |  | 159d | 2011-05-26 | 2012-07-06 | -48d | 0d | TB26 - V - Construct-Winter partly * |  |  |  | UDF_G4 | 2011-04-12 | 2011-11-10 | IMS-C-000165 | 0 | 0 | 934 | 00 | 200 | 200 | C | LND | X | B | XB00 | LUTZ | B | 00 | X | EQ | IMS |  | 91 | Монтаж механического оборудования | M1 |  |  |  |  |  |  |  |  |  |  |  |  |  |  |  |
| IMS-P-000170 |  | Instruments Bulk - at Site | level of effort | 94d | 2011-06-10 A | 2011-10-28 | P3J04BS (other project), P3J04AS (other project), P3J04CS1 (other project), P3J02BS (other project), P3J02DS (other project) |  | 54d | 2011-06-11 | 2011-09-29 | 160d | 0d |  |  |  |  |  |  |  | IMS-P-000170 | 0 | 0 |  | 00 |  |  |  |  |  | J |  | LUTZ |  |  |  | Bulk | IMS |  |  | Прозвонка контуров |  |  |  |  |  |  |  |  |  |  |  |  |  |  |  |  |
| F4730 |  | CA00 General - Installation of LL Equipments | level of effort | 120.88d | 2011-08-24 A | 2012-01-18 | XB500C00 SS |  | 92d | 2011-08-24 | 2012-03-13 | 97d | 0d | TB26 - V - Construct-Winter partly * |  |  |  |  | 2011-04-12 | 2011-10-31 | F4730 | 0 | 0 | 934 | 00 | 200 | 200 | C | LND | X | B | XB00 | LUTZ | B | 00 | X | C | LND |  |  |  |  | XBB |  |  |  |  |  |  |  |  |  |  |  |  |  |  |
|  | M | **Mechanical - Rotating Equipment** |  |  | 2011-05-25 | 2012-01-16 |  |  |  |  |  |  |  |  |  |  |  |  |  |  |  |  |  |  |  |  |  |  |  |  |  |  |  |  |  |  |  |  |  |  |  |  |  |  |  |  |  |  |  |  |  |  |  |  |  |  |  |
| AG-22201-MI01 |  | REACTOR AGITATOR GEAR UNIT |  | 16d | 2011-05-25 A | 2011-06-11 A | XC20130106, XN601301 SS+10d, P3M11S2 (other project) | 100% |  |  |  |  |  |  | Rotating Equipment (w/ lube oil unit) [31.1 t]; Rotating equipment (w/ lube oil unit) [3052.78 h] | 124,400 | 124,400 |  |  |  | AG-22201-MI01 | 3052,78 | 3052,78 |  | 13 |  |  |  |  | X | M |  | 1301 |  |  |  |  |  |  |  |  | EQ |  | 3500,00 | 31,1 | 35000 | in R-22201 +6.90 | AG-22201 | SK1301 | M11 ALL1 REACTORS WITH AGITATORS R-21-/22201) | VNZM |  |  |  |  |  |  |
| AG-21201 |  | REACTOR AGITATOR |  | 15d | 2011-05-26 A | 2011-06-11 A | XB001201 FF, XN201201u, XB001201 SS, XN601201, ER291200 (other project) | 100% |  |  |  |  |  |  | Static Equipment > 10 tons [35 t]; Static equipment >10t [2683.5 h] | 105,000 | 105,000 |  |  |  | AG-21201 | 2683,5 | 2683,5 |  | 12 |  |  |  |  | X | B |  | 1201 |  |  |  |  |  |  |  |  | EQ |  | 2636,25 | 35 | 35000 | in R-21201 +6.90 | AG-21201 | SK1201 | M11 ALL1 REACTORS WITH AGITATORS R-21-/22201) | VNZM |  |  |  |  |  |  |
| AG-22201 |  | REACTOR AGITATOR |  | 30d | 2011-05-26 A | 2011-06-24 A | XN601301, XN201301u | 100% |  | 2011-05-26 | 2011-06-30 |  |  |  | Static Equipment > 10 tons [35 t]; Static equipment >10t [2683.5 h] | 105,000 | 105,000 |  |  |  | AG-22201 | 2683,5 | 2683,5 |  | 13 |  |  |  |  | X | B |  | 1301 |  |  |  |  |  |  |  |  | EQ |  | 2636,25 | 35 | 35000 | in R-22201 +6.90 | AG-21201 | SK1201 | M11 ALL1 REACTORS WITH AGITATORS R-21-/22201) | VNZM | different name in CB |  |  |  |  |  |
| P-23601A/B |  | SUBMERSIBLE PUMPS (P-21701/2/23601A/B/23801) |  | 10d | 2011-10-19 | 2011-10-29 | XM101510 SS |  |  |  |  | 98d | 0d |  | Rotating Equipment (w/o lube oil unit) [1.3 t]; Rotating equipment (w/o lube oil unit) [130.1 h] | 4,553.5 |  |  |  |  | P-23601A/B | 130,1 | 0 |  | 15 |  |  |  |  | X | M |  | 1510 |  |  |  |  |  |  |  |  | EQ |  | 130,10 | 1,301 | 2000 |  | P-23601A/B | SK1510 | M14 SUBMERSIBLE PUMPS (P-21701/2/23601A/B/23801) |  |  | 2011-03-01 | 2011-03-06 | 2011-04-20 | 2011-03-10 |  |
| P-23801 |  | SUBMERSIBLE PUMPS (P-21701/2/23601A/B/23801) |  | 10d | 2011-10-19 | 2011-10-29 | XM101510 SS |  |  |  |  | 98d | 0d |  | Rotating Equipment (w/o lube oil unit) [1.3 t]; Rotating equipment (w/o lube oil unit) [130.1 h] | 4,553.5 |  |  |  |  | P-23801 | 130,1 | 0 |  | 15 |  |  |  |  | X | M |  | 1510 |  |  |  |  |  |  |  |  | EQ |  | 130,10 | 1,301 | 2000 |  | P-23801 | SK1510 | M14 SUBMERSIBLE PUMPS (P-21701/2/23601A/B/23801) |  |  | 2011-03-01 | 2011-03-06 | 2011-04-20 | 2011-03-10 |  |
| SU-23601 |  | SUBMERSIBLE PUMPS (P-21701/2/23601A/B/23801) |  | 5d | 2011-10-19 | 2011-10-24 | XM101510 SS |  |  |  |  | 103d | 5d |  | Rotating Equipment (w/o lube oil unit) [0.7 t]; Rotating equipment (w/o lube oil unit) [70 h] | 2,450 |  |  |  |  | SU-23601 | 70 | 0 |  | 15 |  |  |  |  | X | M |  | 1510 |  |  |  |  |  |  |  |  | EQ |  | 70,00 | 0,7 | 2000 |  | SU-23601 | SK1510 | M14 SUBMERSIBLE PUMPS (P-21701/2/23601A/B/23801) |  |  | 2011-03-01 | 2011-03-06 | 2011-04-20 | 2011-03-10 |  |
| P-23401 |  | SERVICE WATER BOOSTER PUMP (P-21901A/B/23401) |  | 5d | 2012-01-11 | 2012-01-16 | P-21901A/B SS, P3M15S1 (other project), XM00171005 SS, F4730 FF, XC20171015, XM00171005 FF |  |  |  |  | -27d | 80d |  | Rotating Equipment (w/o lube oil unit) [1.3 t]; Rotating equipment (w/o lube oil unit) [130.1 h] | 4,553.5 |  |  |  |  | P-23401 | 130,1 | 0 |  | 17 |  |  |  |  | X | M |  | 1710 |  |  |  |  |  |  |  |  | EQ |  | 130,10 | 0,1 | 2000 | concrete +3.0 | P-23401 | SK1510 | M15CONDENSATE / SERVICE WATER PUMP (P-21901A/B/23401) |  | x | 2011-03-01 | 2011-03-06 | 2011-04-20 | 2011-03-10 | a |
|  | R | **Piping** |  |  | 2010-10-13 | 2012-06-30 |  |  |  |  |  |  |  |  |  |  |  |  |  |  |  |  |  |  |  |  |  |  |  |  |  |  |  |  |  |  |  |  |  |  |  |  |  |  |  |  |  |  |  |  |  |  |  |  |  |  |  |
| IMS-P-000120 |  | AG Piping - Delivery at Site | level of effort | 178d | 2010-10-13 A | 2011-05-21 A | P3R06S1 (other project), P3R06DS1 (other project), P3R06AS1 (other project), P3R06BS1 (other project), P3R06CS1 (other project) | 100% |  |  |  |  |  |  |  |  |  |  | 2010-10-12 | 2011-04-28 | IMS-P-000120 | 0 | 0 | 934 | 00 | 200 | 200 | C | LND | X | R |  | LUTZ | R | 00 | X | AG | IMS |  | 91 | Заводское изготовление трубопроводов |  |  |  |  |  |  |  |  |  |  |  |  |  |  |  |  |
| IMS-P-000110 |  | UG Piping - Delivery at Site | level of effort | 217d | 2010-10-21 A | 2011-07-16 A | P3R02AS1 (other project), P3R02S1 (other project) FF+20d, P3R02BS (other project) FF | 100% |  | 2010-10-22 | 2011-07-16 |  |  |  |  |  |  | UDF_G4 | 2010-10-21 | 2011-04-26 | IMS-P-000110 | 0 | 0 | 934 | 00 | 200 | 200 | C | LND | X | R |  | LUTZ | R | 00 | X | UG | IMS |  | 91 | Заводское изготовление трубопроводов |  |  |  |  |  |  |  |  |  |  |  |  |  |  |  |  |
| IMS-C-000180 |  | Piping Prefabrication (incl. Cooling Water Line) | level of effort | 349d | 2011-02-01 A | 2011-12-22 | XR200C00 SS |  | 100d | 2011-02-01 | 2012-03-29 | 60d | 0d |  |  |  |  | UDF_G4 | 2011-03-10 | 2011-10-22 | IMS-C-000180 | 0 | 0 | 934 | 00 | 200 | 200 | C | LND | X | R | XR20 | LUTZ | R | 00 | X | PRP | IMS |  | 91 | Заводское изготовление трубопроводов | M1 |  |  |  |  |  |  |  |  |  |  |  |  |  |  |  |
| IMS-C-000190 |  | Piping Installation | level of effort | 363.88d | 2011-03-14 A | 2012-06-05 | XR40510405 SS, XR401232 SS, XR40510305 SS, XR40510205 SS, XR403110 SS, XR401233 SS, XR40510105 SS |  | 185d | 2011-03-14 | 2012-07-24 | -19d | 0d | TB26 - V - Construct-Winter partly * |  |  |  | UDF_G4 | 2011-02-07 | 2012-02-07 | IMS-C-000190 | 0 | 0 | 934 | 00 | 200 | 200 | C | LND | X | R | XR40 | LUTZ | R | 00 | X | PI | IMS |  | 91 | Монтаж трубопроводов | M1 |  |  |  |  |  |  |  |  |  |  |  |  |  |  |  |
| IMS-C-000360 |  | Piping Pressure Testing/ Reinstatement | level of effort | 178d | 2011-09-29 | 2012-06-30 | XR601110 SS, XR600C00 SS |  |  |  |  | 232.5d | 0d | TB26 - V - Construct-Winter partly * |  |  |  |  | 2011-05-17 | 2012-03-15 | IMS-C-000360 | 0 | 0 | 934 | 00 | 200 | 200 | C | LND | X | R | XR60 | LUTZ | R | 00 | X | HY | IMS |  | 91 | Монтаж трубопроводов | M1 |  |  |  |  |  |  |  |  |  |  |  |  |  |  |  |

| ID | WBS | Activity | Type | Duration | Start | Finish | Predecessors | Complete | Remaining | Planned start | Planned finish | Total float | Free float | Calendar | UDF_CONTRACT INDICATOR | UDF_SAVE ACT ID | UDF_BUDGETED LABOR UNIT | UDF_ACTUAL LABOR UNIT | Department | Constr. Area | Pro Unit/DocCode | PMT-Area | PMT-Schedule Org | PMT-Phase | PMT-Respons. | WBS Phase | WBS Discipline | WBS Type of Work | WBS Objects | Russia WBS Discipline (Russia) | Russia Construction Area | Russia WBS Phase | IMS | UPT | Zeigen/n. Zeigen | UDF_Vendor Representatives | UDF_CHECK BASELINE | TB26 Ressource Budget | UDF_PREDECESSOR | UDF_INDICATOR | UDF_L3 START DATE | UDF_L3 FINISH DATE | Russia WBS Objects |
| --- | --- | --- | --- | --- | --- | --- | --- | --- | --- | --- | --- | --- | --- | --- | --- | --- | --- | --- | --- | --- | --- | --- | --- | --- | --- | --- | --- | --- | --- | --- | --- | --- | --- | --- | --- | --- | --- | --- | --- | --- | --- | --- | --- |
|  | E | **Electrical** |  |  | 2010-12-04 | 2012-11-12 |  |  |  |  |  |  |  |  |  |  |  |  |  |  |  |  |  |  |  |  |  |  |  |  |  |  |  |  |  |  |  |  |  |  |  |  |  |
| IMS-P-000130 |  | Electrical Itemized Equipment - at Site | level of effort | 243d | 2010-12-04 A | 2011-10-27 | P3E01AS4 (other project), P3E01BS1 (other project), P3E02S1 (other project) | 100% | 53d | 2010-12-04 | 2011-09-27 | 126d | 0d |  | UDF_G4 | IMS-P-000130 | 0 | 0 | 934 | 00 | 91 | 200 | 200 | C | LND | X | E | XE00 | LUTZ | E | 00 | X | IT | IMS |  |  |  |  |  |  |  |  |  |
| IMS-P-000150 |  | Electrical Bulk - at Site | level of effort | 150d | 2011-04-08 A | 2011-10-04 | P3E00S (other project), P3E16S (other project), P3E03S2 (other project), P3E15AS (other project) |  | 33d | 2011-04-09 | 2011-10-04 | 99d | 0d |  | UDF_G4 | IMS-P-000150 | 0 | 0 | 934 | 00 | 91 | 200 | 200 | C | LND | X | E | XE00 | LUTZ | E | 00 | X | B | IMS |  |  |  |  |  |  |  |  |  |
| IMS-C-000260 |  | Installation Electrical w/o Earthing | level of effort | 397d | 2011-04-18 A | 2012-10-20 | XE403120 SS, XE413130 SS, XE411610 SS, XE701600 SS, XE401110 SS, XE401204 SS, XE403110 SS, XE401710 SS, XE405101 SS, XE405402 SS, XE401321 SS |  | 349d | 2011-04-18 | 2012-08-09 | 115.5d | 0d |  | UDF_G4 | IMS-C-000260 | 0 | 0 | 934 | 00 | 91 | 200 | 200 | C | LND | X | E | XE00 | LUTZ | E | 00 | X | EL | IMS | M1 |  |  |  |  |  |  |  |  |
| IMS-C-000280 |  | Installation Heat Tracing | level of effort | 205.88d | 2011-10-29 | 2012-07-09 | XE805401 SS, XE801111 SS, XE801321 SS, XE805402 SS |  |  |  |  | 20.12d | 0d |  |  | IMS-C-000280 | 0 | 0 |  | 00 |  |  |  |  |  | X | E |  | LUTZ |  |  |  | HT | IMS |  | 005 |  |  |  |  |  |  |  |
| IMS-C-000380 |  | Electrical Cable Termination & Testing Substation & RIE's | level of effort | 150.5d | 2012-03-16 | 2012-09-11 | XE60161005 SS |  |  |  |  | -61.5d | 0d |  |  | IMS-C-000380 | 0 | 0 |  | 00 |  |  |  |  |  | X | E |  | LUTZ |  |  |  | ET | IMS |  |  |  |  |  |  |  |  |  |
| IMS-C-000300 |  | Installation F&G Detection Systems | level of effort | 187.12d | 2012-04-03 | 2012-11-12 | XE921410 SS, XE923110 FF, XE923120 SS, XE923130 FF, XE921010 SS, XE921322 SS, XE921222 SS, XE923120 FF, XE921321 SS, XE921130 SS, XE921130 FF, XE921111 FF, XE921200 SS, XE921500 SS, XE921300 FF, XE921221 SS, XE921221 FF, XE921600 SS, XE921700 SS, XE923130 SS, XE923140 SS, XE923140 FF, XE921300 SS, XE921410 FF, XE921600 FF, XE921010 FF, XE921110 SS, XE921500 FF, XE921700 FF, XE923110 SS, XE921110 FF, XE921111 SS, XE921200 FF, XE921222 FF, XE921321 FF, XE921322 FF |  |  |  |  | 118.38d | 0d |  |  | IMS-C-000300 | 0 | 0 |  | 00 |  |  |  |  |  | X | E |  | LUTZ |  |  |  | FGDS | IMS |  |  | x |  |  |  |  |  |  |
| IMS-C-000320 |  | Installation Communication Systems | level of effort | 187d | 2012-04-03 | 2012-11-10 | XE961111 FF, XE961130 SS, XE961500 FF, XE961700 SS, XE963120 FF, XE961010 SS, XE961110 SS, XE961221 FF, XE961222 SS, XE961600 FF, XE961130 FF, XE961110 FF, XE961222 FF, XE961500 SS, XE961600 SS, XE961200 FF, XE961221 SS, XE963110 FF, XE963140 FF, XE961321 FF, XE961111 SS, XE961700 FF, XE963110 SS, XE963130 SS, XE961300 SS, XE961321 SS, XE961322 FF, XE961200 SS, XE963120 SS, XE963130 FF, XE963140 SS, XE961010 FF, XE961300 FF, XE961322 SS |  |  |  |  | 118.5d | 0d |  |  | IMS-C-000320 | 0 | 0 |  | 00 |  |  |  |  |  | X | E |  | LUTZ |  |  |  | CS | IMS |  |  | x |  |  |  |  |  |  |
| IMS-C-000250 |  | Installation Substation Equipment (SWG/Trafo's) | level of effort | 70d | 2012-05-04 | 2012-07-27 | XE201610 FF, XE201610 SS |  |  |  |  | -212.5d | 0d |  |  | IMS-C-000250 | 0 | 0 | 934 | 00 | 91 | 200 | 200 | C | LND | X | E | XE00 | LUTZ | E | 00 | X | SS | IMS |  |  |  |  |  |  |  |  |  |
| X3E105 |  | Installation Main El. Equip. (SWG/Trafo's/Diesel Gen.) | level of effort | 70d | 2012-05-04 | 2012-07-27 | XE200C00 SS, XE201610 SS, XE201610 FF |  |  |  |  | -66.5d | 0d |  |  | X3E105 | 0 | 0 | 934 | 00 | 91 | 200 | 200 | C | LND | X | E | XE00 | LUTZ | E | 00 | X | E&I | LND | M1 |  |  |  |  |  |  |  |  |
| X3E110 |  | Electrical Cable Pulling in-/outdoor (frozen period Dec-Feb) | level of effort | 92d | 2012-05-17 | 2012-09-03 | XE501610 SS |  |  |  |  | -61.5d | 0d |  |  | X3E110 | 0 | 0 | 934 | 00 | 91 | 200 | 200 | C | LND | X | E | XE00 | LUTZ | E | 00 | X | E&I | LND | M1 |  |  |  |  |  |  |  |  |
| IMS-C-000390 |  | Electrical Cable Termination & Testing | level of effort | 101.5d | 2012-06-25 | 2012-10-20 | XE604100 SS |  |  |  |  | -84d | 0d |  |  | IMS-C-000390 | 0 | 0 |  | 00 |  |  |  |  |  | X | E |  | LUTZ |  |  |  | ET | IMS |  |  |  |  |  |  |  |  |  |
|  | J | **Instrumentation** |  |  | 2011-12-10 | 2012-12-15 |  |  |  |  |  |  |  |  |  |  |  |  |  |  |  |  |  |  |  |  |  |  |  |  |  |  |  |  |  |  |  |  |  |  |  |  |  |
| IMS-C-000340 |  | Install Field Instruments | level of effort | 179d | 2011-12-10 | 2012-07-18 | XJ301221 SS, XJ301510 SS, XJ304100, XJ301321 SS |  |  |  |  | -15d | 0d |  |  | IMS-C-000340 | 0 | 0 |  | 00 |  |  |  |  |  | X | J |  | LUTZ |  |  |  | IN | IMS |  |  |  |  |  |  |  |  |  |
| X3J100 |  | Installation Instrumentation | level of effort | 216d | 2012-03-05 | 2012-11-17 | XJ411610 SS, XJ413130 SS |  |  |  |  | -71.5d | 0d |  |  | X3J100 | 0 | 0 | 934 | 00 | 91 | 200 | 200 | C | LND | X | J | XJ00 | LUTZ | J | 00 | X | E&I | LND | M1 |  |  |  |  |  |  |  |  |
| X3J125 |  | Installation DCS/SIS incl. SAT | level of effort | 60d | 2012-04-10 | 2012-06-22 | XJ201610 SS |  |  |  |  | -61.5d | 0d | TB26 - V - Construct-Winter partly * |  | X3J125 | 0 | 0 | 934 | 00 |  |  |  | C | LND | X | J | XJ80 | LUTZ | J | 00 | X | SS | LND | M1 |  |  |  |  |  |  |  |  |
| X3J130 |  | Instrumentation Cable Pulling | level of effort | 79.5d | 2012-05-17 | 2012-08-18 | XJ520C00 SS |  |  |  |  | -47d | 0d | TB26 - T - Construct-Winter-3 (Dec/Jan/Feb free) * |  | X3J130 | 0 | 0 | 934 | 00 | 91 | 200 | 200 | C | LND | X | J | XJ00 | LUTZ | E | 00 | X | E&I | LND | M1 |  |  |  |  |  |  |  |  |
| IMS-C-000420 |  | Inspections/ Mech. Acceptance/ Loop Checks | level of effort | 95.5d | 2012-08-25 | 2012-12-15 | XJ800C00 SS |  |  |  |  | -96d | 0d | TB26 - V - Construct-Winter partly * |  | IMS-C-000420 | 0 | 0 | 934 | 00 |  |  |  | C | LND | X | J | XJ80 | LUTZ | J | 00 | X | LT | IMS | M1 |  |  |  |  |  |  |  |  |
| XJ80176005 |  | CA17 General - Safety Interlock Test |  | 10d | 2012-12-05 | 2012-12-15 | XJ801736 FS-10d, XJ801710 FS-10d, XJ801740 FS-10d, XJ801760, XJ801718 FS-17d, XJ801720, XJ801730 FS-10d, XE601730 |  |  |  |  | -116.5d | 0d | TB26 - 3 - Construction Normal 7days * CA17 |  | XJ80176005 | 0 | 0 | 934 | 17 |  | 200 | 200 | C | LND | X | J | XJ80 | 1700 | J | 17 | X | LT | LND | C9-1 |  |  | 240 | XJ80 | UDF_G3 |  |  |  |
|  | S | **Safety & Environment** |  |  |  |  |  |  |  |  |  |  |  |  |  |  |  |  |  |  |  |  |  |  |  |  |  |  |  |  |  |  |  |  |  |  |  |  |  |  |  |  |  |
|  | W | **Painting** |  |  | 2011-09-29 | 2012-05-11 |  |  |  |  |  |  |  |  |  |  |  |  |  |  |  |  |  |  |  |  |  |  |  |  |  |  |  |  |  |  |  |  |  |  |  |  |  |
| IMS-C-000200 |  | Surf.Protection/Painting (incl. Prefab) | level of effort | 100d | 2011-09-29 | 2012-05-11 | XW505102 SS, XW505104 SS, XW505101 SS, XW505103 SS |  |  |  |  | 273.5d | 0d | TB26 - T - Construct-Winter-3 (Dec/Jan/Feb free) * |  | IMS-C-000200 | 0 | 0 | 934 | 00 |  | 200 | 200 | C | LND | X | W | XW00 | LUTZ | W | 0C | X | PA | IMS | M1 |  |  |  |  |  | 2011-06-03 | 2012-03-15 | 0000 |
|  | V | **Insulation** |  |  | 2011-11-22 | 2012-09-10 |  |  |  |  |  |  |  |  |  |  |  |  |  |  |  |  |  |  |  |  |  |  |  |  |  |  |  |  |  |  |  |  |  |  |  |  |  |
| IMS-C-000210 |  | Insulation Eqpt & Piping | level of effort | 199d | 2011-11-22 | 2012-09-10 | XV300C00 SS, XV500C00 SS |  |  |  |  | -14d | 0d | TB26 - V - Construct-Winter partly * |  | IMS-C-000210 | 0 | 0 | 934 | 00 | 91 | 200 | 200 | C | LND | X | V | XV00 | LUTZ | V | 00 | X | INS | IMS | M1 |  |  |  |  |  | 2011-07-12 | 2012-04-28 |  |

Notes:
- IMS-P-000130: UDF_Actictity Name (Russia): Монтаж электрооборудования
- IMS-P-000150: UDF_Actictity Name (Russia): Монтаж электрооборудования
- IMS-C-000260: UDF_Actictity Name (Russia): Монтаж электрооборудования
- IMS-C-000280: UDF_Actictity Name (Russia): Прокладка электрических кабелей
- IMS-C-000380: UDF_Actictity Name (Russia): Прокладка электрических кабелей
- IMS-C-000300: UDF_Actictity Name (Russia): Прокладка электрических кабелей
- IMS-C-000320: UDF_Actictity Name (Russia): Прокладка электрических кабелей
- IMS-C-000250: UDF_Actictity Name (Russia): Монтаж основного электрооборудования (SWG/Trafo/дизель-генератор)
- X3E105: UDF_Actictity Name (Russia): Монтаж основного электрооборудования (SWG/Trafo/дизель-генератор)
- X3E110: UDF_Actictity Name (Russia): Прокладка электрических кабелей
- IMS-C-000390: UDF_Actictity Name (Russia): Прокладка электрических кабелей
- IMS-C-000340: UDF_Actictity Name (Russia): Прозвонка контуров
- X3J100: UDF_Actictity Name (Russia): Монтаж КИП
- X3J125: UDF_Actictity Name (Russia): Монтаж РСУ, вкл. приемо-сдаточные испытания на площадке
- X3J130: UDF_Actictity Name (Russia): Прокладка кабелей КИП
- IMS-C-000420: UDF_Actictity Name (Russia): Прозвонка контуров
- XJ80176005: Current Status: 110711 WL: PRED FS +0 > FS -10
- IMS-C-000200: UDF_Actictity Name (Russia): Защита поверхностей/окраска (вкл. заводскую)
- IMS-C-000210: UDF_Actictity Name (Russia): Изоляция оборудования и трубопроводов

| ID | WBS | Activity | Type | Duration | Start | Finish | Predecessors | Complete | Remaining | Planned start | Planned finish | Total float | Free float | Constraint | Calendar | UDF_Actictity Name (Russia) | UDF_SAVE ACT ID | UDF_BUDGETED LABOR UNIT | UDF_ACTUAL LABOR UNIT | Department | Constr. Area | PMT-Area | PMT-Respons. | Zeigen/n. Zeigen | WBS Phase | WBS Discipline | WBS Type of Work | WBS Objects | Russia WBS Discipline (Russia) | Russia Construction Area | Russia WBS Phase | IMS | UPT | Russia WBS Objects | Filter | PMT-Schedule Org | PMT-Phase | UDF_CONTRACT FINISH DATE | UDF_CONTRACT ITEM | UDF_CONTRACT FINISH DATE REV1 | Pro Unit/DocCode | UDF_CHECK BASELINE | UDF_CONTRACT START DATE | UDF_CONTRACT DATE PENALIZED | UDF_L3 START DATE | UDF_L3 FINISH DATE | Type of Work | UDF_CONTRACT INDICATOR |
| --- | --- | --- | --- | --- | --- | --- | --- | --- | --- | --- | --- | --- | --- | --- | --- | --- | --- | --- | --- | --- | --- | --- | --- | --- | --- | --- | --- | --- | --- | --- | --- | --- | --- | --- | --- | --- | --- | --- | --- | --- | --- | --- | --- | --- | --- | --- | --- | --- |
|  | 00 | **Milestones Construction** |  |  | 2009-04-01 | 2012-08-25 |  |  |  |  |  |  |  |  |  |  |  |  |  |  |  |  |  |  |  |  |  |  |  |  |  |  |  |  |  |  |  |  |  |  |  |  |  |  |  |  |  |  |
|  | 0B | **General Activities** |  |  | 2009-04-01 | 2012-08-08 |  |  |  |  |  |  |  |  |  |  |  |  |  |  |  |  |  |  |  |  |  |  |  |  |  |  |  |  |  |  |  |  |  |  |  |  |  |  |  |  |  |  |
| X3C090 |  | 1st Soil Investigation Report / Piling Load Test | milestone | 0d | 2009-04-01 A | 2009-04-01 A | EC15000005 (other project) FF | 100% |  |  |  |  |  |  |  | 1ый отчет исследований грунта/испытание свай нагрузкой | X3C090 | 0 | 0 | 934 | 0C | 200 | PMT | M1 | X | 0B | X020 | 0C00 | 0 | 0C | X | MI | LND | 0C00 |  |  |  |  |  |  |  |  |  |  |  |  |  |  |
| XE600C05 |  | Energizing MV SWG CA41 | milestone | 0d | 2011-11-28 | 2011-11-28 | X0300005 FS-1d |  |  |  |  | -62d | 86d | finish on 2011-09-15 |  | Подача питания на подстанцию | XE600C05 | 0 | 0 | 934 | 0C | 200 | LND | C6 | X | 0B | X000 | 0C00 | 0 | 0C | X | ML | OWN | 0C00 | 1 | 200 | C |  |  |  |  |  |  |  |  |  |  |  |
| XE600C00 |  | Energizing Service Area CA31 | milestone | 0d | 2012-06-25 | 2012-06-25 | XE203130, XE204100 FF+25d, XE604100 SF, X0300005 FS+1d |  |  |  |  | -14.5d | 73d |  |  | Подача питания на подстанцию | XE600C00 | 0 | 0 | 934 | 0C | 200 | LND | L2 | X | 0B | X000 | 0C00 | 0 | 0C | X | ML | OWN | 0C00 |  | 200 | C | 2011-10-10 | E-16-05-02 | 2012-01-10 |  |  |  |  |  |  |  |  |
| XE600C10 |  | CA16 - Ready for Energizing | milestone | 0d | 2012-08-08 | 2012-08-08 | XE604100 SF, XE501610 SF+70d, XE201710 SF, XE201610, XE204100 FF+25d, X0300005 FS+1d |  |  |  |  | -205.5d | 0d | finish on 2011-11-29 |  | Подача питания на подстанцию | XE600C10 | 0 | 0 | 934 | 0C | 200 | LND | L2 | X | 0B | X000 | 0C00 | 0 | 0C | X | ML | OWN | 0C00 | 1 | 200 | C | 2011-10-10 | E-16-05-01 | 2011-12-21 |  |  |  |  |  |  |  |  |
|  | C | **Civil Work** |  |  | 2009-11-07 | 2012-05-04 |  |  |  |  |  |  |  |  |  |  |  |  |  |  |  |  |  |  |  |  |  |  |  |  |  |  |  |  |  |  |  |  |  |  |  |  |  |  |  |  |  |  |
| XC150C0010 |  | CA00 General - Start Excavation/Piling | milestone | 0d | 2009-11-07 A | 2009-11-07 A | F2910 FS+1d, EC153140 (other project) | 100% |  |  |  |  |  |  |  | CA00 Общее - Начало экскавационных/сваезабивных работ | XC150C0010 | 0 | 0 | 934 | 0C | 200 | LND | L2 | X | C | XC15 | 0C00 | C | 0C | X | P | LND | 0C00 |  | 200 | C |  |  |  | 91 |  |  |  |  |  |  |  |
| XC200C00 |  | CA00 General - Start Foundation Works | milestone | 0d | 2010-05-24 A | 2010-05-24 A | P3C02D1 (other project), XC153110 | 100% |  |  |  |  |  |  |  | CA00 Общее - Начало бетонных работ, фундаменты | XC200C00 | 0 | 0 | 934 | 0C | 200 | LND | L2 | X | C | XC20 | 0C00 | C | 0C | X | CW | LND | 0C00 |  | 200 | C |  |  |  |  |  |  |  |  |  |  |  |
| XR500C00 |  | CA00 General - Mech. Works Contract placed (CA10, CA11, CA14, CA17, CA52, CA53) | milestone | 0d | 2011-08-08 A | 2011-08-08 A |  | 100% |  |  |  |  |  | start on or after 2011-08-08 |  | CA00 Общее - Начало монтажа подземных сооружений | XC310C00 | 0 | 0 | 934 | 0C | 200 | LND |  | X | R | XR20 | 0C00 | R | 0C | X | PRP | LND | 0C00 |  | 200 | C |  |  |  |  | x |  |  |  |  |  |  |
| XC500C00 |  | CA00 General - Start Finishing Works Subst&RIE's | milestone | 0d | 2011-08-27 | 2011-08-27 | XC401610 |  |  |  |  | -92d | 13d |  |  |  | XC500C00 | 0 | 0 | 934 | 0C | 200 | LND |  | X | C | XC50 | 0C00 | C | 0C | X | CW | LND | 0C00 |  | 200 | C |  |  |  |  |  |  |  |  |  |  |  |
| XC300C00 |  | CA00 General - Start UG Precast Fabrication (Manholes/CB) | milestone | 0d | 2011-09-05 | 2011-09-05 | ER441600 (other project), XC310C00 |  |  |  |  | -108d | 0d |  |  | CA00 Общее - Начало монтажа подземных сооружений | XC300C00 | 0 | 0 | 934 | 0C | 200 | LND | C5 | X | C | XC30 | 0C00 | C | 0C | X | CW | LND | 0C00 |  | 200 | C |  |  |  |  |  |  |  |  |  |  |  |
| XC310C00 |  | CA00 General - UG Contract placed | milestone | 0d | 2011-09-05 | 2011-09-05 |  |  |  |  |  | -108d | 0d | start on or after 2011-09-05 |  | CA00 Общее - Начало монтажа подземных сооружений | XC310C00 | 0 | 0 | 934 | 0C | 200 | LND | C5 | X | C | XC30 | 0C00 | C | 0C | X | CW | LND | 0C00 |  | 200 | C |  |  |  |  | x |  |  |  |  |  |  |
| XC510C00 |  | CA00 General - Finishing Works Contract placed | milestone | 0d | 2011-09-12 | 2011-09-12 |  |  |  |  |  | -105d | 0d | start on or after 2011-09-12 |  |  | XC510C00 | 0 | 0 | 934 | 0C | 200 | LND |  | X | C | XC50 | 0C00 | C | 0C | X | CW | LND | 0C00 |  | 200 | C |  |  |  |  |  |  |  |  |  |  |  |
| XC520C00 |  | CA00 General - Finish False Floor Subst.&RIE's | milestone | 0d | 2012-05-04 | 2012-05-04 | XC521615 FF, XC521625 |  |  |  |  | -212.5d | 0d |  |  |  | XC520C00 | 0 | 0 | 934 | 0C | 200 | LND |  | X | C | XC52 | 0C00 | C | 0C | X | OB | LND | 0C00 |  | 200 | C |  |  |  |  |  |  |  |  |  |  |  |
|  | N | **Structural Steel** |  |  | 2011-02-01 | 2011-03-23 |  |  |  |  |  |  |  |  |  |  |  |  |  |  |  |  |  |  |  |  |  |  |  |  |  |  |  |  |  |  |  |  |  |  |  |  |  |  |  |  |  |  |
| XN100C00 |  | CA00 General - Start Install St.Struc Structures | milestone | 0d | 2011-02-01 A | 2011-02-01 A | P3A00D (other project), XN301610 SS | 100% |  |  |  |  |  |  | TB26 - V - Construct-Winter partly * |  | XN100C00 | 0 | 0 | 934 | 0C | 200 | LND |  | X | N | XN20 | 0C00 | N | 0C | X | SS | LND | 0C00 |  | 200 | C |  |  |  |  |  |  |  |  |  |  |  |
| XN200C00 |  | CA00 General - Start Install Steel Structure Piperacks | milestone | 0d | 2011-03-23 A | 2011-03-23 A | XN205101l SS, P3A00D (other project), XN205102l | 100% |  |  |  |  |  |  |  |  | XN200C00 | 0 | 0 | 934 | 0C | 200 | LND |  | X | N | XN20 | 0C00 | N | 0C | X | MI | LND | 0C00 |  | 200 | C |  |  |  |  |  |  |  |  |  |  |  |
|  | H | **HVAC** |  |  | 2011-04-23 | 2012-02-24 |  |  |  |  |  |  |  |  |  |  |  |  |  |  |  |  |  |  |  |  |  |  |  |  |  |  |  |  |  |  |  |  |  |  |  |  |  |  |  |  |  |  |
| XH000C00 |  | CA00 General - Start Install HVAC Subst.&RIE's | milestone | 0d | 2011-04-23 A | 2011-04-23 A | P3H01D (other project) FS+20d, P3H01SA (other project) | 100% |  |  |  |  |  | as late as possible |  |  | XH000C00 | 0 | 0 | 934 | 0C | 200 | LND |  | X | H | XH00 | 0C00 | H | 0C | X | hvac | LND | 0C00 |  | 200 | C | 2011-02-10 |  |  |  |  | 2011-02-10 | P | 2011-03-17 | 2011-03-17 |  |  |
| XH000C10 |  | CA00 General - Start Testing/Commissioning HVAC | milestone | 0d | 2012-02-24 | 2012-02-24 | XH00161005, X0300060, XH00161007, X0300016, X0300080, XH001610050, XH00161007_1 |  |  |  |  | 46d | 0d |  |  | CA00 Общее - Подача пара для ОВКВ | XH000C10 | 0 | 0 | 934 | 0C | 200 | UIO | L2 | X | H | X030 | 0C00 | H | 0C | X | ML | OWN | 0C00 |  | 200 | C | 2011-05-10 |  |  |  |  | 2011-05-10 | P | 2011-07-13 | 2011-07-13 |  |  |
|  | U | **Package Units** |  |  |  |  |  |  |  |  |  |  |  |  |  |  |  |  |  |  |  |  |  |  |  |  |  |  |  |  |  |  |  |  |  |  |  |  |  |  |  |  |  |  |  |  |  |  |
|  | B | **Mechanical - Stationary Equipment** |  |  | 2010-08-24 | 2012-02-25 |  |  |  |  |  |  |  |  |  |  |  |  |  |  |  |  |  |  |  |  |  |  |  |  |  |  |  |  |  |  |  |  |  |  |  |  |  |  |  |  |  |  |
| XB000C00 |  | CA00 General - Start Prefab Silos / Blenders | milestone | 0d | 2010-08-24 A | 2010-08-24 A | P3ALL4S1 (other project) FS+1d, EL20010 (other project) | 100% |  |  |  |  |  |  | TB26 - V - Construct-Winter partly * |  | XB000C00 | 0 | 0 | 934 | 0C | 200 | LND |  | X | B | XB60 | 0C00 | B | 0C | X | MI | LND | 0C00 |  | 200 | C |  |  |  |  |  |  |  | 2010-08-24 | 2010-08-24 | XBB |  |
| X3B110 |  | HeavyLifts Reactors&Purge Columns | level of effort | 261d | 2010-12-10 A | 2011-12-27 | XB30120110 SS, XB30130110 SS |  | 85d | 2010-12-13 | 2011-12-27 | -61d | 0d |  | TB26 - V - Construct-Winter partly * | Подъем тяжеловесных грузов - реакторы и продувочные колонны | X3B110 | 0 | 0 | 934 | 0C | 200 | LND | M1 | X | B | XB00 | 0C00 | B | 0C | X | MI | LND | 0C00 |  | 200 | C |  |  |  |  |  |  |  | 2010-12-10 | 2011-09-15 | XBB | UDF_G4 |
| IMS-P-000160 |  | Itemized Instruments (Meas. Devices) - at Site | level of effort | 173d | 2011-03-31 A | 2012-02-25 | P3J04AS (other project), P3J04ES (other project), P3J04BS (other project) FF | 100% | 149d | 2011-04-01 | 2011-10-22 | 31d | 0d |  |  | Прозвонка контуров | IMS-P-000160 | 0 | 0 |  | 00 |  |  |  |  | J |  | LUTZ |  |  |  | IT | IMS |  |  |  |  |  |  |  |  |  |  |  |  |  |  |  |
| XB500C00 |  | CA00 General - Start Install Silos / Blenders | milestone | 0d | 2011-08-24 A | 2011-08-24 A | P3A00D (other project), XC40311015_100 SS, E3ALL470 (other project), XB50311005 FS+5d, P3A00S1 (other project) | 100% |  |  |  |  |  | as late as possible | TB26 - V - Construct-Winter partly * |  | XB500C00 | 0 | 0 | 934 | 0C | 200 | LND |  | X | B | XB60 | 0C00 | B | 0C | X | MI | LND | 0C00 |  | 200 | C |  |  |  |  |  |  |  | 2011-04-12 | 2011-04-12 | XBB |  |

Notes:
- XE600C00: Current Status: 07.02.2011 (O. Siegel): Constraint (Finish On 29-Nov-11) wurde rausgenommen. / da im "Original"-Projekt kein Constraint vorhanden war.
- XN100C00: Expenses: XN20 0
- XN200C00: Expenses: XN20 0

| ID | WBS | Activity | Type | Duration | Start | Finish | Predecessors | Complete | Total float | Free float | Constraint | Calendar | UDF_L3 START DATE | UDF_L3 FINISH DATE | UDF_SAVE ACT ID | UDF_BUDGETED LABOR UNIT | UDF_ACTUAL LABOR UNIT | Department | Type of Work | Constr. Area | PMT-Area | PMT-Schedule Org | PMT-Phase | PMT-Respons. | WBS Phase | WBS Discipline | WBS Type of Work | WBS Objects | Russia WBS Discipline (Russia) | Russia Construction Area | Russia WBS Phase | IMS | UPT | Russia WBS Objects | UDF_Actictity Name (Russia) | UDF_CHECK CRITICAL PATH | UDF_CONSTRAINT COMMENT | Zeigen/n. Zeigen | MTA | UDF_CONTRACT START DATE | UDF_ELECTRICAL START | UDF_ELECTRICAL FINISH | UDF_Vendor Representatives | UDF_CONTRACT FINISH DATE |
| --- | --- | --- | --- | --- | --- | --- | --- | --- | --- | --- | --- | --- | --- | --- | --- | --- | --- | --- | --- | --- | --- | --- | --- | --- | --- | --- | --- | --- | --- | --- | --- | --- | --- | --- | --- | --- | --- | --- | --- | --- | --- | --- | --- | --- |
|  | M | **Mechanical - Rotating Equipment** |  |  | 2011-07-30 | 2011-10-13 |  |  |  |  |  |  |  |  |  |  |  |  |  |  |  |  |  |  |  |  |  |  |  |  |  |  |  |  |  |  |  |  |  |  |  |  |  |  |
| XM000C00 |  | CA00 General - Start Installation 1st.Compressor | milestone | 0d | 2011-07-30 A | 2011-07-30 A | XC201232, XN201201l SS+30d, K-21201A/B SS, K-22201A/B SS | 100% |  |  |  | TB26 - V - Construct-Winter partly * | 2011-03-25 | 2011-03-25 | XM000C00 | 0 | 0 | 934 | XBB | 0C | 200 | 200 | C | LND | X | M | XM10 | 0C00 | M | 0C | X | MI | LND | 0C00 |  |  |  |  |  |  |  |  |  |  |
| XM000C0010 |  | CA00 General - Start Installation Extruder Eqpt | milestone | 0d | 2011-10-13 | 2011-10-13 | EX-22401 SS, EX-21401 SS, P3M01SA (other project) |  | 398.5d |  |  | TB26 - V - Construct-Winter partly * | 2011-05-17 | 2011-05-17 | XM000C0010 | 0 | 0 | 934 | XBB | 0C | 200 | 200 | C | LND | X | M | XM00 | 0C00 | M | 0C | X | MI | LND | 0C00 |  |  |  |  |  |  |  |  |  |  |
|  | R | **Piping** |  |  | 2011-02-01 | 2011-09-29 |  |  |  |  |  |  |  |  |  |  |  |  |  |  |  |  |  |  |  |  |  |  |  |  |  |  |  |  |  |  |  |  |  |  |  |  |  |  |
| XR200C00 |  | CA00 General - Start Piping Prefabrication (Cooling Water Line) | milestone | 0d | 2011-02-01 A | 2011-02-01 A | P3A00S3 (other project), P3A00D (other project) FS+6d, ER49311005 (other project) | 100% |  |  | start on or after 2011-02-01 |  | 2011-02-01 | 2011-02-01 | XR200C00 | 0 | 0 | 934 |  | 0C | 200 | 200 | C | LND | X | R | XR20 | 0C00 | R | 0C | X | PRP | LND | 0C00 | CA00 Общее - Начало изготовления труб | Prefabrication | Start on 1.1.11 due to delay civil | L2 |  |  |  |  |  |  |
| XR400C00 |  | CA00 General - Start Piping Installation (Cooling Water Line) | milestone | 0d | 2011-03-10 A | 2011-03-10 A | EF30030 (other project), XR40510105 SS-1d, A1CF0250 (other project) SS-20d | 100% |  |  |  | TB26 - V - Construct-Winter partly * | 2011-02-07 | 2011-02-07 | XR400C00 | 0 | 0 | 934 |  | 0C | 200 | 200 | C | LND | X | R | XR40 | 0C00 | R | 0C | X | PI | LND | 0C00 | CA00 Общее - Начало монтажа трубопроводов |  |  | L2 |  |  |  |  |  |  |
| XR600C00 |  | CA00 General - Start Piping Pressure Tests | milestone | 0d | 2011-09-29 | 2011-09-29 | X0300020, X0300025 |  | -29d | 0d | as late as possible | TB26 - T - Construct-Winter-3 (Dec/Jan/Feb free) * | 2011-05-17 | 2011-05-17 | XR600C00 | 0 | 0 | 934 |  | 0C | 200 | 200 | C | LND | X | R | XR60 | 0C00 | R | 0C | X | HY | LND | 0C00 |  |  |  |  | MTA |  |  |  |  |  |
|  | E | **Electrical** |  |  | 2011-04-18 | 2012-05-04 |  |  |  |  |  |  |  |  |  |  |  |  |  |  |  |  |  |  |  |  |  |  |  |  |  |  |  |  |  |  |  |  |  |  |  |  |  |  |
| XE400C00 |  | CA00 General - Start Install CableTrays (Substation/Service Area) | milestone | 0d | 2011-04-18 A | 2011-04-18 A | XE413130 SS, XE411610 SS, XE405301 SS, XE405300 SS | 100% |  |  |  |  |  |  | XE400C00 | 0 | 0 | 934 |  | 0C | 200 | 200 | C | LND | X | E | XE40 | 0C00 | E | 0C | X | EL | LND | 0C00 |  |  |  |  |  | 2011-03-10 | 2011-04-09 | 2011-04-09 |  |  |
| XE500C01 |  | CA00 General - Cables electr. and instrum. arrived at Site | milestone | 0d | 2011-10-01 | 2011-10-01 |  |  | -50d | 30d | start on 2011-10-01 |  |  |  | XE500C01 | 0 | 0 | 934 |  | 0C | 200 | 200 | C | LND | X | E | XE50 | 0C00 | E | 0C | X | E&I | LND | 0C00 |  |  |  |  | MTA |  | 2011-07-06 | 2011-07-06 |  |  |
| XE500C00 |  | CA00 General - Start Pull E-Cables Subst.&RIE's | milestone | 0d | 2011-10-27 | 2011-10-27 | P3E15AS (other project) |  | -49d | 80.5d | start on 2011-10-01 | TB26 - T - Construct-Winter-3 (Dec/Jan/Feb free) * |  |  | XE500C00 | 0 | 0 | 934 |  | 0C | 200 | 200 | C | LND | X | E | XE50 | 0C00 | E | 0C | X | E&I | LND | 0C00 |  |  |  |  |  |  | 2011-07-06 | 2011-07-06 |  |  |
| XE800C00 |  | CA00 General - Start Heat Tracing | milestone | 0d | 2011-11-03 | 2011-11-03 | P3E19S (other project) |  | 58d | 0d | as late as possible | TB26 - V - Construct-Winter partly * |  |  | XE800C00 | 0 | 0 | 934 |  | 0C | 200 | 200 | C | LND | X | E | XE80 | 0C00 | E | 0C | X | HT | LND | 0C00 |  |  |  |  |  |  |  |  | 005 |  |
| XE200C00 |  | CA00 General - Start Install Trafo's,SG's, MCC's | milestone | 0d | 2012-05-04 | 2012-05-04 | XC521615, P3E01AS4 (other project), P3E02S1 (other project) |  | -212.5d | 0d | as late as possible |  |  |  | XE200C00 | 0 | 0 | 934 |  | 0C | 200 | 200 | C | LND | X | E | XE20 | 0C00 | E | 0C | X | E&I | LND | 0C00 |  |  |  |  |  |  |  |  |  |  |
|  | J | **Instrumentation** |  |  | 2012-03-05 | 2012-08-25 |  |  |  |  |  |  |  |  |  |  |  |  |  |  |  |  |  |  |  |  |  |  |  |  |  |  |  |  |  |  |  |  |  |  |  |  |  |  |
| XJ410C00 |  | CA00 General - Start Install CableTrays Subst&RI | milestone | 0d | 2012-03-05 | 2012-03-05 | XJ411610 SS |  | 329d |  |  |  |  |  | XJ410C00 | 0 | 0 | 934 |  | 0C | 200 | 200 | C | LND | X | J | XJ41 | 0C00 | J | 0C | X | E&I | LND | 0C00 |  |  |  |  |  | 2011-03-10 | 2011-05-07 | 2011-05-07 |  | 2012-04-30 |
| XJ200C00 |  | CA00 General - Start Install Interface Cabinets | milestone | 0d | 2012-04-10 | 2012-04-10 |  |  | -128.5d | 0d | as late as possible |  |  |  | XJ200C00 | 0 | 0 | 934 |  | 0C | 200 | 200 | C | LND | X | J | XJ20 | 0C00 | J | 0C | X | E&I | LND | 0C00 |  |  |  |  |  |  |  |  |  |  |
| XJ520C00 |  | CA00 General - Start Pull Multicore Cables | milestone | 0d | 2012-05-17 | 2012-05-17 | XJ425501, XJ525402 SS |  | -58.5d | 10d |  | TB26 - T - Construct-Winter-3 (Dec/Jan/Feb free) * |  |  | XJ520C00 | 0 | 0 | 934 |  | 0C | 200 | 200 | C | LND | X | J | XJ52 | 0C00 | J | 0C | X | E&I | LND | 0C00 |  |  |  |  |  |  | 2011-07-09 | 2011-07-09 |  |  |
| XJ540C00 |  | CA00 General - Start Pull Singlecore Cables | milestone | 0d | 2012-05-26 | 2012-05-26 | XJ423120, XJ441232 SS+20d, XJ542101 SS, XJ621232 SS+6d |  | -25.5d | 0d |  |  |  |  | XJ540C00 | 0 | 0 | 934 |  | 0C | 200 | 200 | C | LND | X | J | XJ54 | 0C00 | J | 0C | X | E&I | LND | 0C00 |  |  |  |  |  |  | 2011-10-31 | 2011-10-31 |  |  |
| XJ800C00 |  | CA00 General - Start Loop Checks | milestone | 0d | 2012-08-25 | 2012-08-25 | X030410030 |  | -96.5d | 0d |  | TB26 - V - Construct-Winter partly * |  |  | XJ800C00 | 0 | 0 | 934 |  | 0C | 200 | 200 | C | LND | X | J | XJ80 | 0C00 | J | 0C | X | LT | LND | 0C00 |  |  |  |  |  |  |  |  |  |  |
|  | S | **Safety & Environment** |  |  |  |  |  |  |  |  |  |  |  |  |  |  |  |  |  |  |  |  |  |  |  |  |  |  |  |  |  |  |  |  |  |  |  |  |  |  |  |  |  |  |
|  | W | **Painting** |  |  |  |  |  |  |  |  |  |  |  |  |  |  |  |  |  |  |  |  |  |  |  |  |  |  |  |  |  |  |  |  |  |  |  |  |  |  |  |  |  |  |
|  | V | **Insulation** |  |  | 2011-11-22 | 2011-12-21 |  |  |  |  |  |  |  |  |  |  |  |  |  |  |  |  |  |  |  |  |  |  |  |  |  |  |  |  |  |  |  |  |  |  |  |  |  |  |
| XV500C00 |  | CA00 General - Start Insulation Piping | milestone | 0d | 2011-11-22 | 2011-11-22 | F1870 (other project) FS+59.6d |  | 94.92d | 0d | as late as possible | TB26 - V - Construct-Winter partly * | 2011-07-12 | 2011-07-12 | XV500C00 | 0 | 0 | 934 |  | 0C | 200 | 200 | C | LND | X | V | XV50 | 0C00 | V | 0C | X | INS | LND | 0C00 |  |  |  |  |  |  |  |  |  |  |
| XV300C00 |  | CA00 General - Start Insulation Equipment | milestone | 0d | 2011-12-21 | 2011-12-21 | F1870 (other project) FS+60d |  | 30d | 0d | as late as possible | TB26 - V - Construct-Winter partly * | 2011-08-05 | 2011-08-05 | XV300C00 | 0 | 0 | 934 |  | 0C | 200 | 200 | C | LND | X | V | XV30 | 0C00 | V | 0C | X | INS | LND | 0C00 |  |  |  |  |  |  |  |  |  |  |

Notes:
- XR200C00: Current Status: 22.01.2011 (O.Siegel): nach Rьcksprache mit M.Siegel wurde der Starttermin / auf den 01-Feb-11 verschoben. / Expenses: XR20 0
- XR400C00: Expenses: XR20 0
- XR600C00: Expenses: XR60 0
- XE400C00: Current Status: 28.01.2011 (O.Siegel): den Constraint "Start On" 28-Feb-11 / rausgenommen.
- XE500C01: Current Status: 30.04.2011 (O.Siegel): entsprechend der vorliegenden / Informationen werden die Electr. und Instrum. Kabeln erst ab Mitte Okt. 2011 auf / die Baustelle geliefert
- XE500C00: Current Status: 30.04.2011 (O.Siegel): entsprechend dem Kommentar von Hr. Pietsch wurde der / Starttermin auf den 01.Okt.11 gesetzt / 13-01-11 - Volkmann - War auf 22.09.2011 auf Grund so Late as possible / gefixt!
- XV500C00: Expenses: XV50 0
- XV300C00: Expenses: XV30 0

| ID | WBS | Activity | Type | Duration | Start | Finish | Predecessors | Complete | Planned start | Planned finish | Total float | Free float | Constraint | Calendar | Resources | Cost | Actual cost | UDF_BASELINE DEVELOPMENT | UDF_SAVE ACT ID | UDF_BUDGETED LABOR UNIT | UDF_ACTUAL LABOR UNIT | Department | Type of Work | Constr. Area | PMT-Area | PMT-Schedule Org | PMT-Phase | PMT-Respons. | WBS Phase | WBS Discipline | WBS Type of Work | WBS Objects | Russia WBS Discipline (Russia) | Russia Construction Area | Russia WBS Phase | IMS | UPT | Russia WBS Objects | UDF_CHECK BASELINE | Subcontractor | TB26 Ressource Budget | Inquiry/Order No | Comments | Zeigen/n. Zeigen | UDF_Concrete | UDF_CHECK CRITICAL PATH | Check ResLoading | UDF_SELECT UPDATE PROGRESS | TB26 Semantics | UDF_CONTRACT START DATE | UDF_CONTRACT FINISH DATE | UDF_L3 START DATE | UDF_L3 FINISH DATE |
| --- | --- | --- | --- | --- | --- | --- | --- | --- | --- | --- | --- | --- | --- | --- | --- | --- | --- | --- | --- | --- | --- | --- | --- | --- | --- | --- | --- | --- | --- | --- | --- | --- | --- | --- | --- | --- | --- | --- | --- | --- | --- | --- | --- | --- | --- | --- | --- | --- | --- | --- | --- | --- | --- |
|  | 10 | **CA10 - Propylene Recovery Section** |  |  | 2008-09-24 | 2012-09-06 |  |  |  |  |  |  |  |  |  |  |  |  |  |  |  |  |  |  |  |  |  |  |  |  |  |  |  |  |  |  |  |  |  |  |  |  |  |  |  |  |  |  |  |  |  |  |  |
|  | 00 | **CA10 - General** |  |  | 2012-07-04 | 2012-09-06 |  |  |  |  |  |  |  |  |  |  |  |  |  |  |  |  |  |  |  |  |  |  |  |  |  |  |  |  |  |  |  |  |  |  |  |  |  |  |  |  |  |  |  |  |  |  |  |
| X0101010 |  | CA10 General - Construction Completion | milestone | 0d | 2012-07-04 | 2012-07-04 | XC601010, XC301010, XN401010, XE601010, XJ541010, XC191010, XH00101005, XB001010, XN301010, XE501010, XE911015, XJ701010, XN601010, XJ641010, XR401010, XJ301010, XJ391010 |  |  |  | -3.5d | 64d |  | TB26 - 2 - Manuf and Delivy |  |  |  | XC301010 | X0101010 | 0 | 0 | 934 | XNK | 10 | 200 | 200 | C | LND | X | 0B | X010 | 1000 | 0 | 10 | X | MC | LND | 1000 |  |  |  |  |  |  |  |  |  |  |  |  |  |  |  |
| X0101800 |  | CA18 General - Mechanical Completion | milestone | 0d | 2012-07-31 | 2012-07-31 | X0101810 |  |  |  | 249.5d |  |  | TB26 - 2 - Manuf and Delivy |  |  |  |  | X0101800 | 0 | 0 | 934 | XNK | 18 | 200 | 200 | C | LND | X | 0B | X010 | 1810 | 0 | 10 | X | MC | LND | 1000 | x |  |  |  |  |  |  |  |  |  |  |  |  |  |  |
| X0101810 |  | CA18 General - Construction Completion | milestone | 0d | 2012-07-31 | 2012-07-31 | XC101800 |  |  |  | 249.5d | 0d |  | TB26 - 2 - Manuf and Delivy |  |  |  |  | X0101810 | 0 | 0 | 934 | XNK | 18 | 200 | 200 | C | LND | X | 0B | X010 | 1810 | 0 | 10 | X | MC | LND | 1000 | x |  |  |  |  |  |  |  |  |  |  |  |  |  |  |
| X0101000 |  | CA10 General - Mechanical Completion | milestone | 0d | 2012-09-06 | 2012-09-06 | XH00101005, XB001010, XE601010, X0101010, XC601010 FF+20d, XE911015, XV501010, XJ801010 |  |  |  | -12.5d | 114d |  | TB26 - 2 - Manuf and Delivy |  |  |  |  | X0101000 | 0 | 0 | 934 | XNK | 10 | 200 | 200 | C | LND | X | 0B | X010 | 1000 | 0 | 10 | X | MC | LND | 1000 |  |  |  |  |  |  |  |  |  |  |  |  |  |  |  |
|  | 10 | **CA10 - Propylene Recovery Unit Area** |  |  | 2008-09-24 | 2012-09-06 |  |  |  |  |  |  |  |  |  |  |  |  |  |  |  |  |  |  |  |  |  |  |  |  |  |  |  |  |  |  |  |  |  |  |  |  |  |  |  |  |  |  |  |  |  |  |  |
|  | C | **Civil Work** |  |  | 2008-09-24 | 2012-06-13 |  |  |  |  |  |  |  |  |  |  |  |  |  |  |  |  |  |  |  |  |  |  |  |  |  |  |  |  |  |  |  |  |  |  |  |  |  |  |  |  |  |  |  |  |  |  |  |
| XC111010 |  | CA10 PRU Area - Excavation&Surface Prep U/I/O |  | 294d | 2008-09-24 A | 2009-09-30 A | XC111410 FF | 100% |  |  |  |  |  |  |  |  |  |  | XC111010 | 0 | 0 | 934 |  | 10 | 200 | 200 | C | UIO | X | C | XC11 | 1010 | C | 10 | X | EQ | LND | 1010 |  | MO11 |  |  |  |  |  |  |  |  |  |  |  |  |  |
| XC11101005 |  | CA10 PRU Area - Excavation |  | 10d | 2010-03-09 A | 2010-03-19 A | XC11110005 | 100% |  |  |  |  |  |  | Excavation [5850 cbm]; Excavation [2925 h] | 234,000 | 234,000 |  | XC11101005 | 2925 | 2925 | 934 |  | 10 | 200 | 200 | C | MO02 | X | C | XC11 | 1010 | C | 10 | X | P | LND | 1010 |  | MO11 | 2925,00 | 999 |  |  |  |  |  |  |  |  |  |  |  |
| XC11100010 |  | CA10 General - SubBase (Gravel/Geogrid) for Concrete |  | 19d | 2010-03-22 A | 2010-04-13 A | XC11101005 | 100% | 2010-03-22 | 2010-04-12 |  |  |  |  | Sub Base for Concrete/Paving&Roads (Gravel) [3000 cbm]; Subbase for Concrete [3000 h] | 300,000 | 100,000 |  | XC11100010 | 3000 | 3000 | 934 |  | 10 | 200 | 200 | C | MO02 | X | C | XC11 | 1010 | C | 10 | X | P | LND | 1010 |  | MO11 | 3000,00 | 999 |  |  |  |  |  |  |  |  |  |  |  |
| XC151010 |  | CA10 PRU Area - Piling |  | 3d | 2011-04-21 A | 2011-04-25 A | XC11100010, EC151010 (other project) FS+65d, XC111010, F2910, XC11101005 | 100% | 2011-04-21 | 2011-04-23 |  |  |  | TB26 - V - Construct-Winter partly * | Piles driven [56 pcs]; Piles driven [420 h] | 16,800 | 16,800 |  | XC151010 | 420 | 420 | 934 |  | 10 | 200 | 200 | C | MO02 | X | C | XC15 | 1010 | C | 10 | X | P | LND | 1010 |  | MO11 | 420,00 | 999 |  |  |  |  |  |  |  |  |  |  |  |
| XC201010 |  | CA10 PRU Area - Concrete Works Foundations |  | 39d | 2011-05-03 A | 2011-06-24 A | XC151010 FS+3d, EC281010 (other project), EC45101005 (other project), EC441010 (other project) FF | 100% | 2011-05-03 | 2011-06-18 |  |  |  | TB26 - V - Construct-Winter partly * | Concrete works [160 cbm]; Concrete works [4800 h] | 1,533.61 |  |  | XC201010 | 4800 | 4800 | 934 |  | 10 | 200 | 200 | C | CiC | X | C | XC20 | 1010 | C | 10 | X | CW | LND | 1010 |  | MO11 | 4800,00 | 999 | finished on 18.06.2011 | FL |  |  |  |  |  |  |  |  |  |
| XC301010 |  | CA10 PRU Area - UG Installation (incl. Precast Manholes) |  | 40d | 2012-03-02 | 2012-04-24 | XC201010 SS+16d, P3R02S1 (other project) FF, P3S08S (other project) FF+30d, ER441010 (other project), P3R02AS1 (other project), P3R02BS (other project), XC310C00, P3R02S1 (other project), XC300C00 |  |  |  | 15d | 0d | start on or after 2012-03-02 | TB26 - V - Construct-Winter partly * | Cast Iron U/G Piping [230 m]; Concrete Manholes [10 pcs]; Floor Drains / Catch Basins [3 pcs]; Fire water hydrants/monitors [3 pcs]; FRP U/G Piping [40 m]; Cast iron U/G piping [4600 h]; concrete manholes [2750 h]; floor drains / catch basins [75 h]; fire water hydrants/ monitors [187.5 h]; FRP U/G piping [500 h] | 152,750.38 |  | XC301010 | XC301010 | 8112,5 | 0 | 934 |  | 10 | 200 | 200 | C | CiC | X | C | XC30 | 1010 | C | 10 | X | CW | LND | 1010 |  |  | 8112,50 | 999 |  |  | 1 | XC301010 | UG |  |  |  |  |  |  |
| XC191010 |  | CA10 PRU Area - Backfill |  | 40d | 2012-04-02 | 2012-05-19 | XC301010 FF+5d, XC301010 SS+20d, XC911010, XC915201 FF+20d |  |  |  | 15d | 0d |  | TB26 - T - Construct-Winter-3 (Dec/Jan/Feb free) * | Backfill & Compaction [3000 cbm]; Backfill & Compaction [4500 h] | 270,000 |  | XC301010 | XC191010 | 4500 | 0 | 934 |  | 10 | 200 | 200 | C | CiC | X | C | XC19 | 1010 | C | 10 | X | mis | LND | 1010 |  |  | 4500,00 |  |  |  |  |  |  |  |  |  |  |  |  |
| XC601010 |  | CA10 PRU Area - Paving |  | 25d | 2012-05-15 | 2012-06-13 | XC191010 SS+20d, EC601000 (other project) FS+20d, XC191010 FF+20d |  |  |  | 15d | 17.5d |  |  | Concrete paved areas & concrete Roads [2000 sqm]; Open ditches; Gravel [1200 sqm]; Concrete paved areas & concrete roads [7500 h]; open ditches; Gravel [60 h] | 19,816.61 |  | XC301010 | XC601010 | 7560 | 0 | 934 |  | 10 | 200 | 200 | C | CiC | X | C | XC60 | 1010 | C | 10 | X | OB | LND | 1010 |  | MO11 | 7560,00 |  |  |  | 1 |  |  |  |  |  |  |  |  |
|  | N | **Structural Steel** |  |  | 2011-06-25 | 2012-01-10 |  |  |  |  |  |  |  |  |  |  |  |  |  |  |  |  |  |  |  |  |  |  |  |  |  |  |  |  |  |  |  |  |  |  |  |  |  |  |  |  |  |  |  |  |  |  |  |
| XN701000 |  | CA10 PRU Area SK1000 - KMD Assy Drawings | milestone | 0d | 2011-06-25 A | 2011-06-25 A |  | 100% |  |  |  |  | finish on 2011-06-25 | TB26 - V - Construct-Winter partly * |  |  |  |  | XN701000 | 0 | 0 | 934 | XNK | 10 | 200 | 200 | C | LND | X | N | XN05 | 1010 | N | 10 | X | PR | LND | 1000 | x |  |  | 999 |  | KMD |  |  |  |  |  |  |  |  |  |
| XN711000 |  | CA10 PRU Area SK1000 - Steel Deliveries | milestone | 0d | 2011-08-08 A | 2011-08-08 A |  | 100% |  |  |  |  | finish on 2011-08-08 | TB26 - V - Construct-Winter partly * |  |  |  |  | XN711000 | 0 | 0 | 934 | XNK | 10 | 200 | 200 | C | LND | X | N | XN06 | 1010 | N | 10 | X | PR | LND | 1000 |  |  |  | 999 |  | SD |  |  |  | 27.8. |  |  |  |  |  |
| XN301010 |  | CA10 PRU Area SK1001 - Install Prim Steel |  | 20d | 2011-11-22 | 2012-01-10 | XN205201u, XC201010, P3N02XN (other project), XN205201l, XB001010 |  |  |  | -88d | 0d |  | TB26 - V - Construct-Winter partly * | Piperacks, Main Structures [19 t]; Piperacks, Main structures [807.5 h] | 32,300 |  |  | XN301010 | 807,5 | 0 | 934 | XNK | 10 | 200 | 200 | C | LND | X | N | XN20 | 1010 | N | 10 | X | PR | LND | 1010 |  | SM | 807,50 | 999 |  | FL |  |  |  |  | t |  |  |  |  |
| XN401010 |  | CA10 PRU Area SK1001 - Install Railings,Ladders,etc. |  | 20d | 2011-11-22 | 2012-01-10 | XN301010 SS, XB001010 |  |  |  | -88d | 0d |  | TB26 - V - Construct-Winter partly * | Ladders & platforms [6 t]; Ladders & platforms [600 h] | 206.94 |  |  | XN401010 | 600 | 0 | 934 | XNK | 10 | 200 | 200 | C | LND | X | N | XN40 | 1010 | N | 10 | X | SS | LND | 1010 |  | SM | 600,00 |  |  | FL |  |  |  |  |  |  |  |  |  |
| XN601010 |  | CA10 PRU Area SK1001 - Install Gratings |  | 20d | 2011-11-22 | 2012-01-10 | XN401010 FF, PN691010 (other project), XB001010 |  |  |  | -88d | 0d |  | TB26 - V - Construct-Winter partly * | Grating [100 sqm]; Grating [375 h] | 8,019.1 |  |  | XN601010 | 375 | 0 | 934 | XNK | 10 | 200 | 200 | C | LND | X | N | XN60 | 1010 | N | 10 | X | SS | LND | 1010 |  | SM | 375,00 |  |  | FL |  |  |  |  |  |  |  |  |  |
| XN712000 |  | CA10 PRU Area SK1000 - Platforms on PRU |  | 10d | 2011-11-22 | 2011-12-12 | XN711000, XN301010 SS, XN701000, XB001010 |  |  |  | 108d | 10d |  | TB26 - V - Construct-Winter partly * | Piperacks, Main Structures [6 t]; Piperacks, Main structures [255 h] | 10,200 |  |  | XN712000 | 255 | 0 | 934 | XNK | 10 | 200 | 200 | C | LND | X | N | XN30 | 1010 | N | 10 | X | PR | LND | 1010 |  | SM | 255,00 | 999 |  | FL |  |  |  |  | t |  |  |  |  |
|  | H | **HVAC** |  |  | 2012-01-11 | 2012-02-27 |  |  |  |  |  |  |  |  |  |  |  |  |  |  |  |  |  |  |  |  |  |  |  |  |  |  |  |  |  |  |  |  |  |  |  |  |  |  |  |  |  |  |  |  |  |  |  |
| XH00101005 |  | CA10 PRU Area SK1001 - Fresh Air Intake Duct Installation (HVAC) |  | 40d | 2012-01-11 | 2012-02-27 | XN301010, XN601010, XN205201l, XN205201u, XB001010 |  |  |  | 103d | 35d |  |  |  |  |  |  | XH00101005 | 0 | 0 | 934 |  | 10 | 200 | 200 | C | LND | X | H | XH00 | 1010 | H | 11 | X | hvac | LND | 1110 |  | ARMO |  |  |  | D |  |  |  |  |  | 2011-05-25 | 2011-07-10 | 2011-06-04 | 2011-07-14 |

Notes:
- XC111010: P3 Activity Log Info: incl. Dewatering/Drainage
- XC151010: Current Status: 14.03.2011 (O.Siegel): MO11 ist bereit die Pilling-Arbeiten durchzufьhren. / Die Arbeiten wurden vom Civil-Department zurьckgestellt, um Behinderungen / bei der Fertigstellung von CA16 und CA54 zu vermeiden. / 03.02.2011 (O. Siegel): Piling fьr CA10 wird zusammen mit dem Piling CA14 / durchgefьhrt werden, damit die nцtige Gerдtschaft nur einmal auf die Baustelle / befцrdert wird.
- XN711000: Scope: 09.02.2011: weight: 5 ton / Current Status: 20110601 (O.Siegel): bis heute 0 t Stahl auf dem Baufeld

| ID | WBS | Activity | Duration | Start | Finish | Predecessors | Complete | Total float | Free float | Constraint | Calendar | Resources | Cost | Actual cost | TB26 Ressource Budget | Comments | UDF_Text4 | Drawing Indicator | UDF_CONTRACT START DATE | UDF_CONTRACT FINISH DATE | UDF_CONTRACT ITEM | UDF_LEVEL | UDF_PLANNED START | UDF_PLANNED FINISH | UDF_Vendor Representatives | UDF_CONTRACT FINISH DATE REV1 | UDF_CONTRACT START DATE REV1 | UDF_L3 START DATE | UDF_L3 FINISH DATE | UDF_SAVE ACT ID | UDF_BUDGETED LABOR UNIT | UDF_ACTUAL LABOR UNIT | Department | Type of Work | Constr. Area | PMT-Area | PMT-Schedule Org | PMT-Phase | PMT-Respons. | Zeigen/n. Zeigen | WBS Phase | WBS Discipline | WBS Type of Work | WBS Objects | Russia WBS Discipline (Russia) | Russia Construction Area | Russia WBS Phase | IMS | UPT | Russia WBS Objects | Subcontractor | UDF_INDICATOR | TB26 Semantics | TB26 Material Res Values | UDF_ELECTRICAL START | UDF_ELECTRICAL FINISH | UDF_CHECK BASELINE | UDF_COMMENTS_0827 | Filter |
| --- | --- | --- | --- | --- | --- | --- | --- | --- | --- | --- | --- | --- | --- | --- | --- | --- | --- | --- | --- | --- | --- | --- | --- | --- | --- | --- | --- | --- | --- | --- | --- | --- | --- | --- | --- | --- | --- | --- | --- | --- | --- | --- | --- | --- | --- | --- | --- | --- | --- | --- | --- | --- | --- | --- | --- | --- | --- | --- | --- |
|  | U | **Package Units** |  |  |  |  |  |  |  |  |  |  |  |  |  |  |  |  |  |  |  |  |  |  |  |  |  |  |  |  |  |  |  |  |  |  |  |  |  |  |  |  |  |  |  |  |  |  |  |  |  |  |  |  |  |  |  |  |  |
|  | B | **Mechanical - Stationary Equipment** |  | 2011-10-29 | 2011-11-21 |  |  |  |  |  |  |  |  |  |  |  |  |  |  |  |  |  |  |  |  |  |  |  |  |  |  |  |  |  |  |  |  |  |  |  |  |  |  |  |  |  |  |  |  |  |  |  |  |  |  |  |  |  |  |
| XB001010 |  | CA10 PRU Area - Install PRU Container (3pcs) (PK-21301) | 14d | 2011-10-29 | 2011-11-21 | F4730 FF, P3U12S (other project) FS+14d, IMS-C-000165 FF, XC201010, ER291000 (other project) FS+100d, P3B180 (other project) |  | -88d | 0d |  | TB26 - V - Construct-Winter partly * | Propylene Recovery Unit [2375 mhr]; Propylene recovery unit [2375 h] | 237,500 |  | 2375,00 | E-08-01-04 | MKG-40 | UDF_G3 | 2011-09-05 | 2011-09-20 | E-08-01-02 | concrete +0.65 | 2011-09-05 | 2011-09-20 | 019 | 2011-11-29 | 2011-11-15 | 2011-09-05 | 2011-09-17 | XB001010 | 2375 | 0 | 934 | XBB | 10 | 200 | 200 | C | LND | C4 | X | B | XB00 | 1010 | B | 10 | X | EQ | IMS | 1010 | SEM |  |  |  |  |  |  |  |  |
|  | M | **Mechanical - Rotating Equipment** |  |  |  |  |  |  |  |  |  |  |  |  |  |  |  |  |  |  |  |  |  |  |  |  |  |  |  |  |  |  |  |  |  |  |  |  |  |  |  |  |  |  |  |  |  |  |  |  |  |  |  |  |  |  |  |  |  |
|  | R | **Piping** |  | 2011-11-18 | 2012-04-24 |  |  |  |  |  |  |  |  |  |  |  |  |  |  |  |  |  |  |  |  |  |  |  |  |  |  |  |  |  |  |  |  |  |  |  |  |  |  |  |  |  |  |  |  |  |  |  |  |  |  |  |  |  |  |
| XR201010 |  | CA10 PRU Area - Piping Prefabrication | 19.99d | 2011-11-18 | 2011-12-10 | ER491010 (other project), IMS-C-000180 FF, XR200C00 FS+20d, XR500C00 FS+15d |  | -110d | 0d | as late as possible |  | A/G piping prefabrication [470 Fpi]; A/G Piping (Prefab) [1762.5 h] | 3,344.37 |  | 1762,50 |  |  |  |  |  |  |  |  |  |  |  |  | 2011-07-15 | 2011-08-03 | XR201010 | 1762,5 | 0 | 934 |  | 10 | 200 | 200 | C | LND |  | X | R | XR20 | 1010 | R | 10 | X | PRP | LND | 1010 |  |  |  |  |  |  |  |  |  |
| XR401010 |  | CA10 PRU Area - Piping Installation | 35d | 2012-01-11 | 2012-03-20 | P3J04CS1 (other project), XR201010 SS+6d, XN601010, XR201010 FS+20d, IMS-C-000190 FF, XB001010 FF-10d, P3J01AS (other project), P3J04IS (other project) |  | -88d | 0d |  | TB26 - V - Construct-Winter partly * | A/G piping field installation [600 Fpi]; Control & Shut-off valves [8 pcs]; A/G Piping (Field) [3750 h]; Install Control & Shut-off Valves [42 h] | 13,564.54 |  | 3792,00 | E-06-03-01 |  | UDF_G3 | 2011-07-10 | 2011-09-30 | E-06-03-01 |  | 2011-08-23 | 2011-10-14 |  |  |  | 2011-08-26 | 2011-09-29 | XR401010 | 3792 | 0 | 934 |  | 10 | 200 | 200 | C | LND | C4 | X | R | XR40 | 1010 | R | 10 | X | PI | IMS | 1010 |  |  |  |  |  |  |  |  |  |
| XR601010 |  | CA10 PRU Area - Piping Pressure Tests | 20d | 2012-03-19 | 2012-04-12 | XR401010 FS-7d, XR605201 SS |  | 15d | 0d |  | TB26 - T - Construct-Winter-3 (Dec/Jan/Feb free) * |  |  |  | 152LF | E-06-03-01 |  | UDF_G3 | 2011-07-10 | 2011-09-30 | E-06-03-01 |  | 2011-10-07 | 2011-10-29 |  |  |  | 2011-09-21 | 2011-10-10 | XR601010 | 0 | 0 | 934 |  | 10 | 200 | 200 | C | LND | C4 | X | R | XR60 | 1010 | R | 10 | X | HY | IMS | 1010 |  |  |  |  |  |  |  |  |  |
| XR801010 |  | CA10 PRU Area - Piping Reinstatement | 20d | 2012-04-02 | 2012-04-24 | XR601010 FF+10d, IMS-C-000190 FF, IMS-C-000360 FF |  | 15d | 0d |  | TB26 - V - Construct-Winter partly * |  |  |  | 76LF | E-06-03-01 |  | UDF_G3 | 2011-07-10 | 2011-09-30 | E-06-03-01 |  | 2011-10-27 | 2011-11-13 |  |  |  | 2011-10-03 | 2011-10-21 | XR801010 | 0 | 0 | 934 |  | 10 | 200 | 200 | C | LND | C4 | X | R | XR80 | 1010 | R | 10 | X | PI | LND | 1010 |  |  |  |  |  |  |  |  |  |
|  | E | **Electrical** |  | 2011-06-07 | 2012-07-04 |  |  |  |  |  |  |  |  |  |  |  |  |  |  |  |  |  |  |  |  |  |  |  |  |  |  |  |  |  |  |  |  |  |  |  |  |  |  |  |  |  |  |  |  |  |  |  |  |  |  |  |  |  |  |
| XC911010 |  | CA10 PRU Area - Install Earthing System_CIVIL | 10d | 2011-06-07 A | 2011-06-18 A | XC201010 FF, EE901010 (other project) | 100% |  |  |  | TB26 - V - Construct-Winter partly * | Grounding & Lightning [100 pcs]; Grounding & Lightning [1125 h] | 45,000 | 45,000 | 1125,00 | finished on 18.06.2011 |  |  |  |  |  |  |  |  |  |  |  |  |  | XC911010 | 1125 | 1125 | 934 |  | 10 | 200 | 200 | C | LND |  | X | C | XE91 | 1010 | C | 10 | X | EA | LND | 1010 | MO11 |  |  |  |  |  |  |  |  |
| XE911015 |  | CA10 PRU Area - Install Earthing System_E/I | 20d | 2012-01-11 | 2012-02-27 | XN301010, XN712000, XB001010 |  | 98d | 100.5d |  | TB26 - V - Construct-Winter partly * |  |  |  | 115pcs |  |  |  |  |  |  |  |  |  |  |  |  |  |  | XE911015 | 0 | 0 | 934 |  | 10 | 200 | 200 | C | LND |  | X | E | XE91 | 1010 | E | 10 | X | EA | LND | 1010 | URMA | UDF_G3 |  |  |  |  |  |  |  |
| XE401010 |  | CA10 PRU Area - Install Cable Trays | 20d | 2012-02-28 | 2012-03-27 | XE405102, XR401010 FS-15d, XN301010, XB001010 |  | -88d | 0d |  | TB26 - V - Construct-Winter partly * | Cable trays/conduits [280 m]; Cable trays [840 h] | 33,600 |  | 840,00 |  |  |  |  |  |  |  |  |  |  |  |  |  |  | XE401010 | 840 | 0 | 934 |  | 10 | 200 | 200 | C | LND | C4 | X | E | XE40 | 1010 | E | 10 | X | EL | LND | 1010 | URMA | UDF_G2 | m | 405 | 2011-10-08 | 2011-10-31 | x | to delete install cable trays 5102 ?? Equipment 100% |  |
| XE801010 |  | CA10 PRU Area - Install Heat Tracing | 35d | 2012-03-12 | 2012-04-24 | P3E19S (other project), E3E1950 (other project), IMS-C-000280 FF, XR401010 FS-15d, XR601010 FF+10d |  | 82d | 0d |  | TB26 - V - Construct-Winter partly * | Electrical Heat Tracing [3400 m]; Electrical heat tracing [1700 h] | 68,000 |  | 1700,00 |  |  |  |  |  |  |  |  |  | 005 |  |  |  |  | XE801010 | 1700 | 0 | 934 |  | 10 | 200 | 200 | C | LND | C4 | X | E | XE80 | 1010 | E | 10 | X | HT | IMS | 1010 | URMA |  |  |  |  |  |  | Piping 50% |  |
| XE341010 |  | CA10 PRU Area - Install Local Operation Panels | 20d | 2012-03-28 | 2012-04-20 | XE401010 |  | 290.5d |  |  | TB26 - V - Construct-Winter partly * | Field Panels [3 pcs]; Field panels [60 h] | 2,400 |  | 60,00 |  |  |  |  |  |  |  |  |  |  |  |  |  |  | XE341010 | 60 | 0 | 934 |  | 10 | 200 | 200 | C | LND | C4 | X | E | XE34 | 1010 | E | 10 | X | EL | LND | 1010 | URMA | UDF_G2 |  |  |  |  |  | Cable pulling to connected piperacks |  |
| XE701010 |  | CA10 PRU Area - Install Lighting &Small Power | 40d | 2012-04-10 | 2012-05-28 | P3E09S (other project), XP341610 FS+50d, XR401010 FF+10d, XJ401010, EE761010 (other project), XE401010, IMS-C-000260 FF, XH00101005, XC201010 |  | 239.5d | 0d |  |  | Cable Pulling [1000 m]; Lighting illuminates [100 pcs]; Cable pulling [500 h]; Lighting (iluminates) [1000 h] | 60,000 |  | 1500,00 |  |  |  |  |  |  |  |  |  |  |  |  |  |  | XE701010 | 1500 | 0 | 934 |  | 10 | 200 | 200 | C | LND |  | X | E | XE70 | 1010 | E | 10 | X | EL | LND | 1010 | URMA | UDF_G3 |  |  |  |  |  | HVAC ducts | x |
| XE921010 |  | CA10 PRU Area - Install Fire Detection System | 20d | 2012-05-29 | 2012-06-21 | XJ401010, XE701010 |  | 239.5d | 0d |  |  | Fire Detection System; Fire detection system |  |  | 0,00 |  |  |  |  |  |  |  |  |  |  |  |  |  |  | XE921010 | 0 | 0 | 934 |  | 10 | 200 | 200 | C | UIO |  | X | E | XE92 | 1010 | E | 10 | X | FGDS | IMS | 1010 |  |  |  |  |  |  | x |  | x |
| XE961010 |  | CA10 PRU Area - Install Communication System | 20d | 2012-05-29 | 2012-06-21 | XJ401010, P3E13S (other project), XE921010 SS, XE701010 |  | 239.5d |  |  |  | Communication System |  |  | 0,00 |  |  |  |  |  |  |  |  |  |  |  |  |  |  | XE961010 | 0 | 0 | 934 |  | 10 | 200 | 200 | C | LND |  | X | E | XE96 | 1010 | E | 10 | X | CS | IMS | 1010 |  |  |  |  |  |  | x |  | x |
| XE501010 |  | CA10 PRU Area - Cable Pulling Electric | 20d | 2012-05-29 | 2012-06-22 | XE505201 SS+10d, XE500C01, XE401010, P3E15CS (other project), P3E15AS (other project), P3E15BS (other project) |  | -2.5d | 0d |  | TB26 - V - Construct-Winter partly * | Cable Pulling [2400 m]; Cable pulling [1200 h] | 48,000 |  | 1200,00 |  |  |  |  |  |  |  |  |  |  |  |  |  |  | XE501010 | 1200 | 0 | 934 |  | 10 | 200 | 200 | C | LND | C4 | X | E | XE50 | 1010 | E | 10 | X | E&I | LND | 1010 | URMA | UDF_G2 | m | 2500 | 2011-11-01 | 2011-12-06 |  | Cable pulling to connected piperacks |  |
| XE601010 |  | CA10 PRU Area - Cable Termination & Testing | 20d | 2012-06-09 | 2012-07-04 | XE501010 FS-10d, IMS-C-000390 FF, XB001010 |  | -2.5d | 0d |  |  | Cable connecting [130 pcs]; Cable connecting [325 h] | 13,000 |  | 325,00 |  |  |  |  |  |  |  |  |  |  |  |  |  |  | XE601010 | 325 | 0 | 934 |  | 10 | 200 | 200 | C | LND | C4 | X | E | XE60 | 1010 | E | 10 | X | ET | IMS | 1010 | URMA | UDF_G3 |  |  |  |  |  | Equipment 100% |  |
|  | J | **Instrumentation** |  | 2012-02-28 | 2012-09-06 |  |  |  |  |  |  |  |  |  |  |  |  |  |  |  |  |  |  |  |  |  |  |  |  |  |  |  |  |  |  |  |  |  |  |  |  |  |  |  |  |  |  |  |  |  |  |  |  |  |  |  |  |  |  |
| XJ321010 |  | CA10 PRU Area - Install Junction Boxes | 20d | 2012-02-28 | 2012-03-27 | P3J06ES (other project) FS+14d, XN601010, XB001010, P3J06FS (other project), EJ321010 (other project), XR401010 FS-15d |  | 13d | 0d |  | TB26 - V - Construct-Winter partly * | Junction Boxes/Cabinets/Panels [12 pcs]; Install Junction Boxes/ Cabinets/ Panels [300 h] | 12,000 |  | 300,00 |  |  |  |  |  |  |  |  |  |  |  |  |  |  | XJ321010 | 300 | 0 | 934 |  | 10 | 200 | 200 | C | LND |  | X | J | XJ32 | 1010 | J | 10 | X | IN | LND | 1010 | URMA | UDF_G3 |  |  |  |  |  | Civil 100%, Equipment 100%, Piping 50% |  |
| XJ401010 |  | CA10 PRU Area - Install Secondary Cable Trays | 15d | 2012-03-23 | 2012-04-09 | XJ321010 FF+10d, XR401010 SS+25d, XE401010 FF, XB001010 |  | 13d | 0d |  |  | Secondary cable trays [150 m]; Install secondary cable trays [562.5 h] | 22,500 |  | 562,50 |  |  |  |  |  |  |  |  |  |  |  |  |  |  | XJ401010 | 562,5 | 0 | 934 |  | 10 | 200 | 200 | C | LND |  | X | J | XJ40 | 1010 | J | 10 | X | IN | LND | 1110 | URMA | UDF_G3 | m | 840 | 2011-08-27 | 2011-11-05 |  | Equipment 100% | x |
| XJ301010 |  | CA10 PRU Area - Install Field Instruments | 20d | 2012-04-07 | 2012-04-30 | P3J12DS (other project), P3J05S (other project), P3J14S (other project), P3J13BS (other project), XR401010 FS-15d, P3J13S (other project), P3J04ES (other project), P3J13CS (other project), P3J14BS (other project), P3J14AS (other project), P3J13AS (other project), P3J12BS (other project), P3J12AS (other project), IMS-C-000340 FF, P3J07AS (other project), EJ361010 (other project), XR801010 FS-15d, XB001010 |  | 15d | 0d |  | TB26 - V - Construct-Winter partly * | Field Instruments [58 pcs]; Install field instruments [319 h] | 12,760 |  | 319,00 |  |  |  |  |  |  |  |  |  |  |  |  |  |  | XJ301010 | 319 | 0 | 934 |  | 10 | 200 | 200 | C | LND |  | X | J | XJ30 | 1010 | J | 10 | X | IN | IMS | 1010 | URMA | UDF_G3 |  |  |  |  |  | Equipment 100% |  |
| XJ441010 |  | CA10 PRU Area - Install Conduits to Instrm | 20d | 2012-04-10 | 2012-05-03 | XJ321010, XJ401010, XE401010, XB001010, XR401010 SS+17d |  | 13d | 0d |  |  |  |  |  |  |  |  |  |  |  |  |  |  |  |  |  |  |  |  | XJ441010 | 0 | 0 | 934 |  | 10 | 200 | 200 | C | LND |  | X | J | XJ44 | 1010 | J | 10 | X | IN | LND | 1010 | URMA | UDF_G3 |  |  |  |  |  | Equipment 100% |  |
| XJ701010 |  | CA10 PRU Area - Instrument Tubing | 20d | 2012-04-19 | 2012-05-14 | XJ301010 FF+10d, XR401010 |  | 25d | 12d |  |  |  |  |  |  |  |  |  |  |  |  |  |  |  |  |  |  |  |  | XJ701010 | 0 | 0 | 934 |  | 10 | 200 | 200 | C | LND |  | X | J | XJ70 | 1010 | J | 10 | X | IN | LND | 1010 | URMA | UDF_G3 |  |  |  |  |  |  |  |
| XJ541010 |  | CA10 PRU Area - Pulling Singlecore Cables | 20d | 2012-04-25 | 2012-05-19 | XJ301010 FF+15d, XE500C01, X3J130 FF, EJ801010 (other project), XJ441010 SS, IMS-C-000340 FF, XJ401010 |  | 30d | 17d |  | TB26 - V - Construct-Winter partly * | Singlecore cables [3900 m]; Pull singlecore cables [2925 h] | 117,000 |  | 2925,00 |  |  |  |  |  |  |  |  |  |  |  |  |  |  | XJ541010 | 2925 | 0 | 934 |  | 10 | 200 | 200 | C | LND | C4 | X | J | XJ54 | 1010 | J | 10 | X | IN | LND | 1010 | URMA | UDF_G3 | m | 3735 | 2011-11-23 | 2012-01-11 |  |  |  |
| XJ391010 |  | CA10 PRU Area - Install Earthing Field Eqpt | 20d | 2012-05-04 | 2012-05-28 | XJ301010 FF+20d, XJ441010, XE401010, XJ401010 |  | 13d | 0d |  |  |  |  |  |  |  |  |  |  |  |  |  |  |  |  |  |  |  |  | XJ391010 | 0 | 0 | 934 |  | 10 | 200 | 200 | C | LND | C4 | X | J | XJ39 | 1010 | J | 10 | X | IN | LND | 1010 | URMA | UDF_G3 |  |  |  |  |  |  |  |
| XJ641010 |  | CA10 PRU Area - Termin Singlecore Cables | 15d | 2012-05-29 | 2012-06-15 | IMS-C-000340 FF, XJ541010 FF+5d, XJ301010, XJ321010, XJ391010, XJ701010 |  | 13d | 15.5d |  | TB26 - V - Construct-Winter partly * | Termination Field [705 mhr]; Termination field [705 h] | 70,500 |  | 705,00 |  |  |  |  |  |  |  |  |  |  |  |  |  |  | XJ641010 | 705 | 0 | 934 |  | 10 | 200 | 200 | C | LND | C4 | X | J | XJ64 | 1010 | J | 10 | X | IN | LND | 1010 | URMA | UDF_G3 |  |  |  |  |  |  |  |
| XJ521010 |  | CA10 PRU Area - Pulling Multicore Cables | 20d | 2012-05-31 | 2012-06-25 | XE500C01, XJ525201 SS+10d, P3E00S (other project), XJ321010 SS+5d, XE401010, XJ525401 SS+12d |  | 32.5d | 0d |  | TB26 - V - Construct-Winter partly * | Multicore cables [900 m]; Pull multicore cables [450 h] | 18,000 |  | 450,00 |  |  |  |  |  |  |  |  |  |  |  |  |  |  | XJ521010 | 450 | 0 | 934 |  | 10 | 200 | 200 | C | LND | C4 | X | J | XJ52 | 1010 | J | 10 | X | IN | LND | 1010 | URMA | UDF_G3 | m | 650 | 2011-10-29 | 2011-11-30 |  |  |  |
| XJ621010 |  | CA10 PRU Area - Termin Multicore Cables | 20d | 2012-06-13 | 2012-07-06 | XJ521010 FF+10d, XJ321010 |  | 32.5d | 43d |  | TB26 - V - Construct-Winter partly * | Termination Field [705 mhr]; Termination field [705 h] | 70,500 |  | 705,00 |  |  |  |  |  |  |  |  |  |  |  |  |  |  | XJ621010 | 705 | 0 | 934 |  | 10 | 200 | 200 | C | LND | C4 | X | J | XJ62 | 1010 | J | 10 | X | IN | LND | 1010 | URMA | UDF_G3 |  |  |  |  |  |  |  |
| XJ801010 |  | CA10 PRU Area - Inspections/ Mech. Acceptance/ Loop Checks | 10d | 2012-08-25 | 2012-09-06 | X3J120, X3J100 FF, YY0100 FF, XJ701010 SS, XJ641010 FF+5d, X030410030, XJ391010 SS+10d, IMS-C-000420 FF, XE601010, XJ621010 |  | -10.5d | 0d |  | TB26 - V - Construct-Winter partly * | Loop Checks [50 pcs]; Loop checks [250 h] | 10,000 |  | 250,00 |  |  |  |  |  |  |  |  |  |  |  |  |  |  | XJ801010 | 250 | 0 | 934 |  | 10 | 200 | 200 | C | LND | C4 | X | J | XJ80 | 1010 | J | 10 | X | LT | IMS | 1010 | URMA | UDF_G3 |  |  |  |  |  |  |  |

Notes:
- XB001010: Current Status: 17.01.11 (Siegel): die Dauer wurde von 10 Tage auf 14 Tage (entsprechend / dem Vertrag) geдndert. / Scope: 20110908 (O.Siegel): die PRU Container werden nach der Auslieferung sofort / auf die Fundamente draufgestellt. AnschlieЯend mьssen die ET die Heizung / installieren, da sie PRUґs beheizt werden mьssen. / Stahlmontage kann in 2012 vorgenommen werden.
- XE911015: UDF_PREDECESSOR: XN30, DEL XE40, DEL XE80, DEL XJ40, Civil 100%, Equipment 100%
- XE401010: UDF_PREDECESSOR: XN30, Piping 50%
- XE801010: Current Status: "Heat Tracing" muss nach den Rohrleitungen und VOR der / Isolierung erfolgen / UDF_PREDECESSOR: XR40, Piping 50% pressure tests
- XE341010: UDF_PREDECESSOR: XE40, Equipment 100%, Piping 50%
- XE701010: UDF_PREDECESSOR: XE40, Civil 100%, HVAC ducts, Finishing works partly
- XE501010: UDF_PREDECESSOR: XE40, XE50, DEL XE34
- XE601010: UDF_PREDECESSOR: XE50, Equipment 100%
- XJ321010: UDF_PREDECESSOR: Civil 100%, Equipment 100%, Piping 50%
- XJ401010: UDF_PREDECESSOR: Equipment 100%
- XJ301010: UDF_PREDECESSOR: XR80, XR40, Equipment 100%, Piping 50%
- XJ441010: UDF_PREDECESSOR: XE40, XJ32, XJ40, Equipment 100%, Piping 50%
- XJ701010: UDF_PREDECESSOR: XJ30
- XJ541010: UDF_PREDECESSOR: XJ30, XJ42, XJ44
- XJ391010: UDF_PREDECESSOR: XJ30, XJ42, XJ44, DEL XJ32, DEL XR40
- XJ641010: UDF_PREDECESSOR: XJ30, XJ32, XJ39, XJ54, XJ70
- XJ521010: UDF_PREDECESSOR: XE40, XJ32, XJ52
- XJ621010: UDF_PREDECESSOR: XJ32, XJ52
- XJ801010: UDF_PREDECESSOR: XE60, XJ39, XJ62, XJ64, XJ70

| ID | WBS | Activity | Type | Duration | Start | Finish | Predecessors | Complete | Planned start | Planned finish | Total float | Free float | Constraint | Calendar | Resources | Cost | Actual cost | TB26 Ressource Budget | UDF_L3 START DATE | UDF_L3 FINISH DATE | UDF_SAVE ACT ID | UDF_BUDGETED LABOR UNIT | UDF_ACTUAL LABOR UNIT | Department | Constr. Area | PMT-Area | PMT-Schedule Org | PMT-Phase | PMT-Respons. | Zeigen/n. Zeigen | WBS Phase | WBS Discipline | WBS Type of Work | WBS Objects | Russia WBS Discipline (Russia) | Russia Construction Area | Russia WBS Phase | IMS | UPT | Russia WBS Objects | UDF_CONTRACT FINISH DATE | UDF_CONTRACT ITEM | Type of Work | Inquiry/Order No | UDF_BASELINE DEVELOPMENT | Subcontractor | Comments | UDF_SELECT UPDATE PROGRESS | UDF_CHECK RESOURCE DATES | Check ResLoading | UDF_Concrete | UDF_CHECK CRITICAL PATH | 4 week lookahead | UDF_CONTRACT INDICATOR | UDF_CONTRACT DATE PENALIZED | UDF_PENALIZED START | UDF_PENALIZED FINISH | Filter | UDF_SELECT |
| --- | --- | --- | --- | --- | --- | --- | --- | --- | --- | --- | --- | --- | --- | --- | --- | --- | --- | --- | --- | --- | --- | --- | --- | --- | --- | --- | --- | --- | --- | --- | --- | --- | --- | --- | --- | --- | --- | --- | --- | --- | --- | --- | --- | --- | --- | --- | --- | --- | --- | --- | --- | --- | --- | --- | --- | --- | --- | --- | --- |
|  | S | **Safety & Environment** |  |  |  |  |  |  |  |  |  |  |  |  |  |  |  |  |  |  |  |  |  |  |  |  |  |  |  |  |  |  |  |  |  |  |  |  |  |  |  |  |  |  |  |  |  |  |  |  |  |  |  |  |  |  |  |  |  |
|  | W | **Painting** |  |  | 2012-04-02 | 2012-05-07 |  |  |  |  |  |  |  |  |  |  |  |  |  |  |  |  |  |  |  |  |  |  |  |  |  |  |  |  |  |  |  |  |  |  |  |  |  |  |  |  |  |  |  |  |  |  |  |  |  |  |  |  |  |
| XW501010 |  | CA10 PRU Area - Surf.Protection Piping |  | 30d | 2012-04-02 | 2012-05-07 | IMS-C-000200 FF, XR201010 SS, XR801010 FF+10d |  |  |  | 82d | 0d |  |  | Piping painting [192 sqm]; Piping painting [480 h] | 564.66 |  | 480,00 | 2011-10-05 | 2011-11-02 | XW501010 | 480 | 0 | 934 | 10 | 200 | 200 | C | LND | C4 | X | W | XW50 | 1010 | W | 10 | X | PA | LND | 1010 |  |  |  |  |  |  |  |  |  |  |  |  |  |  |  |  |  |  |  |
|  | V | **Insulation** |  |  | 2012-04-07 | 2012-05-19 |  |  |  |  |  |  |  |  |  |  |  |  |  |  |  |  |  |  |  |  |  |  |  |  |  |  |  |  |  |  |  |  |  |  |  |  |  |  |  |  |  |  |  |  |  |  |  |  |  |  |  |  |  |
| XV301010 |  | CA10 PRU Area - Insulation Equipment |  | 30d | 2012-04-07 | 2012-05-14 | XR401010, IMS-C-000210 FF, XE801010 SS+20d |  |  |  | 82d | 0d |  | TB26 - T - Construct-Winter-3 (Dec/Jan/Feb free) * | Equipment insulation [200 sqm]; Equipment insulation [2500 h] | 403.54 |  | 2500,00 | 2011-10-07 | 2011-11-08 | XV301010 | 2500 | 0 | 934 | 10 | 200 | 200 | C | LND | C4 | X | V | XV30 | 1010 | V | 10 | X | INS | LND | 1010 | 2012-03-30 | E-13-03 |  |  |  |  |  |  |  |  |  |  |  |  |  |  |  |  |  |
| XV501010 |  | CA10 PRU Area - Insulation Piping |  | 30d | 2012-04-13 | 2012-05-19 | XE801010 SS+20d, IMS-C-000210 FF, XW501010 FF+10d, XR601010 SS+10d, XR601010 FF+20d, XV301010 FF+5d |  |  |  | 82d | 92.5d |  | TB26 - T - Construct-Winter-3 (Dec/Jan/Feb free) * | Piping insulation [200 sqm]; Piping insulation [1500 h] | 1,608.26 |  | 1500,00 | 2011-10-18 | 2011-11-24 | XV501010 | 1500 | 0 | 934 | 10 | 200 | 200 | C | LND | C4 | X | V | XV50 | 1010 | V | 10 | X | INS | LND | 1010 | 2012-04-30 | E-13-01 |  |  |  |  |  |  |  |  |  |  |  |  |  |  |  |  |  |
|  | 11 | **CA11 - Offgas Compression Line 1+2** |  |  | 2008-09-24 | 2012-11-13 |  |  |  |  |  |  |  |  |  |  |  |  |  |  |  |  |  |  |  |  |  |  |  |  |  |  |  |  |  |  |  |  |  |  |  |  |  |  |  |  |  |  |  |  |  |  |  |  |  |  |  |  |  |
|  | 00 | **CA11 - General** |  |  | 2008-09-24 | 2012-11-13 |  |  |  |  |  |  |  |  |  |  |  |  |  |  |  |  |  |  |  |  |  |  |  |  |  |  |  |  |  |  |  |  |  |  |  |  |  |  |  |  |  |  |  |  |  |  |  |  |  |  |  |  |  |
|  | 0B | **General Activities** |  |  | 2012-10-17 | 2012-11-13 |  |  |  |  |  |  |  |  |  |  |  |  |  |  |  |  |  |  |  |  |  |  |  |  |  |  |  |  |  |  |  |  |  |  |  |  |  |  |  |  |  |  |  |  |  |  |  |  |  |  |  |  |  |
| X0101110 |  | CA11 General - Construction Completion | milestone | 0d | 2012-10-17 | 2012-10-17 | XE801110, F-21302, V-21320, XN401110, F-21303, HO-21001, K-22301, XE701110, XE911112, K-21301, F-22303, XE701111, XH00111005, XE911115, XC501110, F-22302, XN601110, XC801111, HO-21003, V-22320, XJ391110, XJ391111, XJ641110, XJ641111 |  |  |  | -108.5d | 3d |  | TB26 - 2 - Manuf and Delivy |  |  |  |  |  |  | X0101110 | 0 | 0 | 934 | 11 | 200 | 200 | C | LND |  | X | 0B | X010 | 1100 | 0 | 11 | X | MC | LND | 1100 |  |  | XNK | 2DC8460 |  |  |  |  |  |  |  |  |  |  |  |  |  |  |  |
| X0101100 |  | CA11 General - Mechanical Completion | milestone | 0d | 2012-11-13 | 2012-11-13 | XC601100, XN801111, HO-21003, XE911112, XC501110, XH00111010, K-21301, XE701110, XE601111 FF, V-21320, XC801111, XV501110 FF, HO-21001, XJ801111 FF, XV501111, V-22320, XE701111, K-22301, F-21302, F-22302, XC191100, X0101110, XV301110 FF, XH00111005, XE601110 FF, XE911115, XJ801110 FF, F-21303, F-22303, XV301111, XC111196125, XC111196105 |  |  |  | -80.5d | 46d |  | TB26 - 2 - Manuf and Delivy |  |  |  |  |  |  | X0101100 | 0 | 0 | 934 | 11 | 200 | 200 | C | LND |  | X | 0B | X010 | 1100 | 0 | 11 | X | MC | LND | 1100 |  |  | XNK | 2DC8460 | XC301100 |  |  |  |  |  |  |  |  |  |  |  |  |  |  |
|  | C | **Civil Work** |  |  | 2008-09-24 | 2012-07-06 |  |  |  |  |  |  |  |  |  |  |  |  |  |  |  |  |  |  |  |  |  |  |  |  |  |  |  |  |  |  |  |  |  |  |  |  |  |  |  |  |  |  |  |  |  |  |  |  |  |  |  |  |  |
| XC111100 |  | CA11 General - Excavation&Surface Prep U/I/O |  | 294d | 2008-09-24 A | 2009-09-30 A | XC111300 SS | 100% |  |  |  |  |  |  |  |  |  |  |  |  | XC111100 | 0 | 0 | 934 | 11 | 200 | 200 | C | UIO |  | X | C | XC11 | 1100 | C | 11 | X | EQ | LND | 1100 |  |  |  |  |  | MO11 |  |  |  |  |  |  |  |  |  |  |  |  |  |
| XC11110005 |  | CA11 General - Excavation |  | 17d | 2010-02-13 A | 2010-03-04 A | XC111100 | 100% |  |  |  |  |  |  | Excavation [9500 cbm]; Excavation [4750 h] | 380,000 | 380,000 | 4750,00 |  |  | XC11110005 | 4750 | 4750 | 934 | 11 | 200 | 200 | C | MO02 |  | X | C | XC11 | 1100 | C | 10 | X | P | LND | 1010 |  |  |  | 999 |  | MO11 |  |  |  |  |  |  |  |  |  |  |  |  |  |
| XC11110010 |  | CA11 General - SubBase (Gravel/Geogrid) for Concrete |  | 17d | 2010-03-18 A | 2010-04-07 A | XC11110005 | 100% | 2010-03-18 | 2010-04-06 |  |  |  |  | Sub Base for Concrete/Paving&Roads (Gravel) [10950 cbm]; Subbase for Concrete [10950 h] | 1,095,000 | 365,000 | 10950,00 |  |  | XC11110010 | 10950 | 10950 | 934 | 11 | 200 | 200 | C | MO02 |  | X | C | XC11 | 1100 | C | 10 | X | P | LND | 1010 |  |  |  | 999 |  | MO11 |  |  |  |  |  |  |  |  |  |  |  |  |  |
| XC151100 |  | CA11 General - Piling |  | 28d | 2010-06-09 A | 2010-07-10 A | EC151111 (other project) FF+5d, XC111100, XC11110010 FS+15d, IMS-C-000010 FF, EC151110 (other project) FS+6d, XC11110005 FS+11d, F2910 | 100% |  |  |  |  |  |  | Piles driven [391 pcs]; Piles driven [2933 h] | 746.48 |  | 2933,00 |  |  | XC151100 | 2933 | 2933 | 934 | 11 | 200 | 200 | C | MO02 | D | X | C | XC15 | 1100 | C | 11 | X | P | LND | 1100 |  |  |  |  |  | MO11 |  |  |  |  |  |  |  |  |  |  |  |  |  |
| XC191100 |  | CA11 General - Backfill |  | 72d | 2011-07-18 A | 2011-08-13 A | XC911110 FF+10d, XC911111 FF+10d, XC911110 | 100% | 2011-07-18 | 2011-10-08 |  |  |  | TB26 - T - Construct-Winter-3 (Dec/Jan/Feb free) * | Backfill & Compaction [11500 cbm]; Backfill & Compaction [17250 h] | 1,035,000 | 1,035,000 | 34500,00 |  |  | XC191100 | 17250 | 0 | 934 | 11 | 200 | 200 | C | MO04 |  | X | C | XC19 | 1100 | C | 11 | X | UG | LND | 1100 |  |  |  |  | XC301100 | MO11 | Start 5.9. | 27.8. | actual finish | X |  |  |  |  |  |  |  |  |  |
| XC301100 |  | CA11 General - UG Installation (incl. Precast Manholes) |  | 40d | 2011-09-08 | 2011-10-24 | P3R02S1 (other project) FF, EC301100 (other project) FS+5d, XC300C00 SS, P3R02BS (other project), ER441100 (other project), XC20111005 SS+20d, P3R02BS (other project) FF+20d, P3R02S1 (other project), XC310C00, P3C02D4 (other project) FS+20d, P3R02AS1 (other project) |  |  |  | 20d | 66d |  | TB26 - V - Construct-Winter partly * | Cast Iron U/G Piping [190 m]; Floor Drains / Catch Basins [2.5 pcs]; Concrete Manholes [20 pcs]; Fire water hydrants/monitors [1.5 pcs]; FRP U/G Piping [85 m]; Cast iron U/G piping [3800 h]; floor drains / catch basins [62.5 h]; concrete manholes [5500 h]; fire water hydrants/ monitors [93.75 h]; FRP U/G piping [1062.5 h] | 273,461.69 |  | 21037,50 |  |  | XC301100 | 10518,75 | 0 | 934 | 11 | 200 | 200 | C | CiC | C5 | X | C | XC30 | 1100 | C | 11 | X | UG | LND | 1100 |  |  |  |  | XC301100 |  |  |  |  | UG | 1 | XC301100 |  |  |  |  |  |  |  |
| XC111196115 |  | CA11 General - UG Installation (incl. Precast Manholes) |  | 40d | 2012-04-02 | 2012-05-19 | XC191100 SS |  |  |  | 42d | 0d | start on or after 2012-04-02 | TB26 - V - Construct-Winter partly * | Cast Iron U/G Piping [190 m]; Floor Drains / Catch Basins [2.5 pcs]; Concrete Manholes [20 pcs]; Fire water hydrants/monitors [1.5 pcs]; FRP U/G Piping [85 m]; Cast iron U/G piping [3800 h]; floor drains / catch basins [62.5 h]; concrete manholes [5500 h]; fire water hydrants/ monitors [93.75 h]; FRP U/G piping [1062.5 h] | 273,461.69 |  | 21037,50 |  |  | XC301100 | 10518,75 | 0 | 934 | 11 | 200 | 200 | C | CiC | C5 | X | C | XC30 | 1100 | C | 11 | X | UG | LND | 1100 |  |  |  |  | XC301100 |  |  |  |  | UG | 1 | XC301100 |  |  |  |  |  |  |  |
| XC111196105 |  | CA11 General - Backfill |  | 40d | 2012-04-25 | 2012-06-13 | XC111196115 SS+20d, XC111196115 FF+10d |  |  |  | 42d | 0d |  | TB26 - T - Construct-Winter-3 (Dec/Jan/Feb free) * | Backfill & Compaction [11500 cbm]; Backfill & Compaction [17250 h] | 1,035,000 |  | 34500,00 |  |  | XC191100 | 17250 | 0 | 934 | 11 | 200 | 200 | C | MO04 |  | X | C | XC19 | 1100 | C | 11 | X | UG | LND | 1100 |  |  |  |  | XC301100 | MO11 |  |  |  | X |  |  |  |  |  |  |  |  |  |
| XC111196125 |  | CA11 General - Paving inside / outside |  | 20d | 2012-06-01 | 2012-06-25 | XC111196105 SS+20d, XC111196105 FF+10d |  |  |  | 52d | 119.5d |  |  | Concrete paved areas & concrete Roads [1250 sqm]; Open ditches; Gravel [1200 sqm]; Concrete paved areas & concrete roads [4687.5 h]; open ditches; Gravel [60 h] | 13,763.48 |  | 9495,00 |  |  | XC601100 | 4747,5 | 0 | 934 | 11 | 200 | 200 | C | MO04 |  | X | C | XC60 | 1100 | C | 11 | X | OB | LND | 1100 |  |  |  |  | XC301100 | MO11 |  |  |  |  | 1 |  |  |  |  |  |  |  |  |
| XC601100 |  | CA11 General - Paving inside / outside |  | 20d | 2012-06-14 | 2012-07-06 | XC191100 SS+20d, XC40111015, XC191100 FF+10d, EC601000 (other project), EC601100 (other project), XC111196105 |  |  |  | 42d | 109.5d |  |  | Concrete paved areas & concrete Roads [1250 sqm]; Open ditches; Gravel [1200 sqm]; Concrete paved areas & concrete roads [4687.5 h]; open ditches; Gravel [60 h] | 13,763.48 |  | 9495,00 |  |  | XC601100 | 4747,5 | 0 | 934 | 11 | 200 | 200 | C | MO04 |  | X | C | XC60 | 1100 | C | 11 | X | OB | LND | 1100 |  |  |  |  | XC301100 | MO11 |  | 27.8. |  |  | 1 |  |  |  |  |  |  |  |  |
|  | 04 | **CA11 - Structures inside Offgas Compr Bldg** |  |  |  |  |  |  |  |  |  |  |  |  |  |  |  |  |  |  |  |  |  |  |  |  |  |  |  |  |  |  |  |  |  |  |  |  |  |  |  |  |  |  |  |  |  |  |  |  |  |  |  |  |  |  |  |  |  |
|  | 10 | **CA11 - Offgas Compressor Building** |  |  | 2010-09-01 | 2012-11-13 |  |  |  |  |  |  |  |  |  |  |  |  |  |  |  |  |  |  |  |  |  |  |  |  |  |  |  |  |  |  |  |  |  |  |  |  |  |  |  |  |  |  |  |  |  |  |  |  |  |  |  |  |  |
|  | C | **Civil Work** |  |  | 2010-09-01 | 2012-05-29 |  |  |  |  |  |  |  |  |  |  |  |  |  |  |  |  |  |  |  |  |  |  |  |  |  |  |  |  |  |  |  |  |  |  |  |  |  |  |  |  |  |  |  |  |  |  |  |  |  |  |  |  |  |
| XC20111005 |  | CA11 ComprBldg - Concrete Works Bldg |  | 194d | 2010-09-01 A | 2011-06-23 A | XC200C10, EC48111003 (other project) FS+5d, EC48111005 (other project) FS+10d, EC45111005 (other project) FF, P3C02D1 (other project), XC151100 SS+72d | 100% |  |  |  |  |  | TB26 - V - Construct-Winter partly * | Concrete works [970 cbm]; Concrete works [29100 h] | 1,164,000 | 660,000 | 29100,00 |  |  | XC20111005 | 29100 | 29100 | 87A | 11 | 200 | 200 | E | MO03 | D | X | C | XC20 | 1110 | C | 11 | X | mai | LND | 1110 |  |  |  |  |  | MO11 |  |  |  |  |  |  |  |  |  |  |  |  |  |
| XC20111010 |  | CA11 ComprBldg - Concrete Works Compr Fdtn |  | 174d | 2010-09-13 A | 2011-06-10 A | XC151100, P3C02D1 (other project), XC200C10, EC28111010 (other project) FS+10d, EC261110 (other project) FF, XC20111005 SS+10d | 100% |  |  |  |  |  | TB26 - V - Construct-Winter partly * | Concrete works [930 cbm]; Concrete works [27900 h] | 1,116,000 | 1,116,000 | 27900,00 |  |  | XC20111010 | 27900 | 27900 | 934 | 11 | 200 | 200 | C | MO03 | D | X | C | XC20 | 1110 | C | 11 | X | mai | LND | 1110 |  |  |  |  |  | MO11 | steel structure can start. floor not finished | x |  |  |  |  | x |  |  |  |  |  |  |
| XC40111005 |  | CA11 ComprBldg - Precast Concrete Elements |  | 41d | 2011-04-01 A | 2011-05-20 A | XCC02D2, EC48111009 (other project) FS+6d, EC48111004 (other project) FS+84d, P3C02D3 (other project) FF, F2910 | 100% |  |  |  |  |  |  |  |  |  |  |  |  | XC40111005 | 0 | 0 | 934 | 11 | 200 | 200 | C | MO04 | D | X | C | XC20 | 1110 | C | 11 | X | pre | LND | 1110 |  |  |  |  |  | MO11 |  |  |  |  |  |  | x |  |  |  |  |  |  |
| XC40111015 |  | CA11 ComprBldg - Erection Precast Elements |  | 82d | 2011-04-22 A | 2011-07-30 A | XC40111005 FS-25d, XC20111005 | 100% | 2011-04-22 | 2011-07-29 |  |  |  |  | Precast Concrete Works [205 cbm]; Precast concrete works [512 h] | 20,500 | 18,000 | 512,00 |  |  | XC40111015 | 512 | 450 | 934 | 11 | 200 | 200 | C | MO04 | D | X | C | XC40 | 1110 | C | 11 | X | OB | LND | 1110 |  |  |  |  |  | MO11 | columns finished, walls will be finished end July |  |  |  |  |  |  | UDF_G4 |  |  |  |  |  |
| XC40111020 |  | CA11 ComprBldg - Erection Precast Elements finished | milestone | 0d | 2011-07-29 A | 2011-07-29 A | XC40111015 FF, IMS-C-000110 FF | 100% |  |  |  |  |  |  |  |  |  |  |  |  | XC40111020 | 0 | 0 | 934 | 11 | 200 | 200 | C | MO04 | D | X | C | XC40 | 1110 | C | 11 | X | OB | LND | 1110 |  |  |  |  |  | MO11 |  |  |  |  |  |  |  | UDF_G4 | P | 2011-05-30 | 2011-05-30 |  |  |
| XC501110 |  | CA11 ComprBldg - Finishing Works Rooms |  | 80d | 2012-02-21 | 2012-05-29 | HO-21001 FF, EC501110 (other project) FS+20d, HO-21003 FF, V-21320 FF, V-22320 FF, XC510C00 FS+15d, XC001100 FF+20d, XN801110 FS-20d |  |  |  | 17.5d | 0d |  |  | Finishing Works - Compressor Building CA11 [25025 mhr]; Finishing Works - Compressor building CA11 [25025 h] | 2,502,500 |  | 25025,00 |  |  | XC501110 | 25025 | 0 | 934 | 11 | 200 | 200 | C | CiC |  | X | C | XC50 | 1110 | C | 11 | X | OB | LND | 1110 |  |  |  |  |  |  |  |  |  |  | 1 |  |  |  |  |  |  | x | XC50 |
| XC501110_1 |  | CA11 ComprBldg - Plastering and Painting (Finishing Works) |  | 20d | 2012-02-21 | 2012-03-17 | XC501110 SS |  |  |  | 17.5d | 0d |  |  |  |  |  | 25025,00 |  |  | XC501110 | 25025 | 0 | 934 | 11 | 200 | 200 | C | CiC |  | X | C | XC50 | 1110 | C | 11 | X | OB | LND | 1110 |  |  |  |  |  |  |  |  |  |  | 1 |  |  |  |  |  |  | x |  |

Notes:
- XW501010: P3 Activity Log Info: Clarification Surface Protection during Prefab
- XC111100: P3 Activity Log Info: incl. Dewatering/Drainage
- XC151100: P3 Activity Log Info: 505 dp expected
- XC301100: P3 Activity Log Info: Clarification Prefab / Catch Basins/pulling pits / Expenses: (New Expense Item) 0
- XC111196115: P3 Activity Log Info: Clarification Prefab / Catch Basins/pulling pits / Expenses: (New Expense Item) 0
- XC20111005: Current Status: 11.06.2011 (O.Siegel): Steel structure can start. Floor will be done later
- XC20111010: Current Status: 19.02.2011 (O.Siegel): die Fundamente fьr / die Compressorn werden entspr. dem Terminplan abgeschlossen: / 23-Mrz-11
- XC40111005: Current Status: 14.03.2011 (O.Siegel): MO11 hat mit den Arbeiten noch nicht begonnen. / 19.02.2011 (O. Siegel): noch nicht beauftragt.
- XC40111015: P3 Activity Log Info: excl. openings for Compressor Lifts / Current Status: 14.05.2011 (O.Siegel): Die Frostschьrze wird spдter / erstellt / 05.02.2011 (O. Siegel): Endtermin mit MO11 am 04.02.2011besprochen: / 30-Apr-11
- XC40111020: P3 Activity Log Info: excl. openings for Compressor Lifts
- XC501110: Steps: Unloading; Prefab; (New step)
- XC501110_1: Steps: Unloading; Prefab; (New step)

| ID | WBS | Activity | Type | Duration | Start | Finish | Predecessors | Complete | Total float | Free float | Constraint | Calendar | Resources | Cost | Actual cost | TB26 Ressource Budget | UDF_SAVE ACT ID | UDF_CHECK BASELINE | UDF_BUDGETED LABOR UNIT | UDF_ACTUAL LABOR UNIT | Department | Type of Work | Constr. Area | PMT-Area | PMT-Schedule Org | PMT-Phase | PMT-Respons. | Zeigen/n. Zeigen | WBS Phase | WBS Discipline | WBS Type of Work | WBS Objects | Russia WBS Discipline (Russia) | Russia Construction Area | Russia WBS Phase | IMS | UPT | Russia WBS Objects | UDF_SELECT UPDATE PROGRESS | UDF_CONTRACT START DATE | UDF_CONTRACT FINISH DATE | UDF_CONTRACT ITEM | TB26 Semantics | Subcontractor | Inquiry/Order No | Filter | UDF_SELECT | UDF_L3 START DATE | UDF_L3 FINISH DATE | UDF_Weight (ton) | WEIGHT | UDF_LEVEL | UDF_PO No | UDF_TAG No | UDF_Object No | UDF_DELIVERY DATE PO | UDF_DELIVERY DATE DISPATCH PLANNED | UDF_DELIVERY DATE TO SITE PLANNED | UDF_DELIVERY DATE SITE NEED DATE | UDF_SHIPMENT No | UDF_PACKAGE | UDF_SUPPLIER | UDF_Vendor Representatives | UDF_CONTRACT FINISH DATE REV1 | UDF_CONTRACT START DATE REV1 | Comments | Drawing Indicator | UDF_PLANNED START | UDF_PLANNED FINISH | UDF_CONTRACT INDICATOR | TB26 Material Res Values | UDF_ELECTRICAL START | UDF_ELECTRICAL FINISH | geplanter Start | geplantes Ende |
| --- | --- | --- | --- | --- | --- | --- | --- | --- | --- | --- | --- | --- | --- | --- | --- | --- | --- | --- | --- | --- | --- | --- | --- | --- | --- | --- | --- | --- | --- | --- | --- | --- | --- | --- | --- | --- | --- | --- | --- | --- | --- | --- | --- | --- | --- | --- | --- | --- | --- | --- | --- | --- | --- | --- | --- | --- | --- | --- | --- | --- | --- | --- | --- | --- | --- | --- | --- | --- | --- | --- | --- | --- | --- | --- | --- |
|  | N | **Structural Steel** |  |  | 2011-02-28 | 2012-04-04 |  |  |  |  |  |  |  |  |  |  |  |  |  |  |  |  |  |  |  |  |  |  |  |  |  |  |  |  |  |  |  |  |  |  |  |  |  |  |  |  |  |  |  |  |  |  |  |  |  |  |  |  |  |  |  |  |  |  |  |  |  |  |  |  |  |  |  |  |  |
| XN701105 |  | CA11 ComprBldg SK1105 - KMD Assy Drawings | milestone | 0d | 2011-02-28 A | 2011-02-28 A |  | 100% |  |  | finish on 2011-02-25 | TB26 - V - Construct-Winter partly * |  |  |  | 22t | XN701105 | x | 0 | 0 | 934 | XNK | 11 | 200 | 200 | C | LND | KMD | X | N | XN05 | 1110 | N | 11 | X | SS | LND | 1110 |  |  |  |  |  |  |  |  |  |  |  |  |  |  |  |  |  |  |  |  |  |  |  |  |  |  |  |  |  |  |  |  |  |  |  |  |  |
| XN701101 |  | CA11 ComprBldg SK1101 - KMD Assy Drawings | milestone | 0d | 2011-03-07 A | 2011-03-07 A |  | 100% |  |  | finish on 2011-03-07 | TB26 - V - Construct-Winter partly * |  |  |  | 22t | XN701101 | x | 0 | 0 | 934 | XNK | 11 | 200 | 200 | C | LND | KMD | X | N | XN05 | 1110 | N | 11 | X | SS | LND | 1110 |  |  |  |  |  |  |  |  |  |  |  |  |  |  |  |  |  |  |  |  |  |  |  |  |  |  |  |  |  |  |  |  |  |  |  |  |  |
| XN711101 |  | CA11 ComprBldg SK1101/00 - Steel Deliveries | milestone | 0d | 2011-08-16 A | 2011-08-16 A |  | 100% |  |  | finish on or after 2011-08-15 | TB26 - 3 - Construction Normal 7days * CA17 |  |  |  | 22t | XN711101 |  | 0 | 0 | 934 | XNK | 11 | 200 | 200 | C | LND | SD | X | N | XN06 | 1110 | N | 11 | X | SS | LND | 1110 | 27.8. |  |  |  |  |  |  |  |  |  |  |  |  |  |  |  |  |  |  |  |  |  |  |  |  |  |  |  |  |  |  |  |  |  |  |  |  |
| XN711105 |  | CA11 ComprBldg SK1105 - Steel Deliveries | milestone | 0d | 2011-08-16 A | 2011-08-16 A |  | 100% |  |  | finish on or after 2011-08-15 | TB26 - 3 - Construction Normal 7days * CA17 |  |  |  | 22t | XN711105 |  | 0 | 0 | 934 | XNK | 11 | 200 | 200 | C | LND | SD | X | N | XN06 | 1110 | N | 11 | X | SS | LND | 1110 | 27.8. |  |  |  |  |  |  |  |  |  |  |  |  |  |  |  |  |  |  |  |  |  |  |  |  |  |  |  |  |  |  |  |  |  |  |  |  |
| XN201110 |  | CA11 ComprBldg SK1101/00/05 - Install Primary Steel |  | 30d | 2011-10-25 | 2011-12-14 | XN701101, XC40111020, EC701110 (other project), P3N02KN (other project) FS-5d, XC911111, XC40111015, XN711101 FF+10d, XN205201u |  | -150d | 0d |  | TB26 - V - Construct-Winter partly * | Piperacks, Main Structures [279 t]; Piperacks, Main structures [11857.5 h] | 975.6 |  | 11857,50 | XN201110 |  | 11857,5 | 0 | 934 | XNK | 11 | 200 | 200 | C | LND | D | X | N | XN20 | 1110 | N | 11 | X | SS | LND | 1110 |  | 2011-03-15 | 2011-04-15 | E-04-01 | t | SM |  |  |  |  |  |  |  |  |  |  |  |  |  |  |  |  |  |  |  |  |  |  |  |  |  |  |  |  |  |  |  |
| XN801110 |  | CA11 ComprBldg - Cladding Works Walls/Roof |  | 40d | 2011-11-24 | 2012-02-29 | XC40111015, XN201110 SS+20d |  | -100d | 0d |  | TB26 - V - Construct-Winter partly * | Cladding [2950 sqm]; Cladding [14750 h] | 590,000 |  | 14750,00 | XN801110 |  | 14750 | 0 | 934 |  | 11 | 200 | 200 | C | LND | D | X | N | XN80 | 1110 | N | 11 | X | OB | LND | 1110 |  |  |  |  |  | SM |  |  |  |  |  |  |  |  |  |  |  |  |  |  |  |  |  |  |  |  |  |  |  |  |  |  |  |  |  |  |  |
| XN301110 |  | CA11 ComprBldg SK1105/00 - Install Eqpt Platforms |  | 10d | 2012-02-20 | 2012-03-06 | EN27111005 (other project), XN701105, P3N02AN (other project), XN711105 FF+10d, XN205201u, K-21301, K-22301 |  | 72d | 0d |  | TB26 - V - Construct-Winter partly * | Ladders & platforms [8 t]; Ladders & platforms [800 h] | 88.69 |  | 800,00 | XN301110 | x | 800 | 0 | 934 | XNK | 11 | 200 | 200 | C | LND |  | X | N | XN30 | 1110 | N | 11 | X | SS | LND | 1110 |  |  |  |  | t | SM | 2DC8460 |  |  |  |  |  |  |  |  |  |  |  |  |  |  |  |  |  |  |  |  |  |  |  |  |  |  |  |  |  |  |
| XN601110 |  | CA11 ComprBldg SK1105/00 - Install Gratings |  | 20d | 2012-03-07 | 2012-04-04 | XN401110 FF, PN691110 (other project) |  | 72d | 164.5d |  | TB26 - V - Construct-Winter partly * | Grating [380 sqm]; Grating [1425 h] | 2,586.81 |  | 1425,00 | XN601110 |  | 1425 | 0 | 934 | XNK | 11 | 200 | 200 | C | LND |  | X | N | XN60 | 1110 | N | 11 | X | SS | LND | 1110 |  |  |  |  |  | SM |  |  |  |  |  |  |  |  |  |  |  |  |  |  |  |  |  |  |  |  |  |  |  |  |  |  |  |  |  |  |  |
| XN401110 |  | CA11 ComprBldg SK1105/00 - Install Railings,Ladders,etc. |  | 10d | 2012-03-22 | 2012-04-04 | XN301110 SS+20d, EC701110 (other project) |  | 72d | 0d |  | TB26 - V - Construct-Winter partly * | Ladders & platforms | 51.74 |  | 0,00 | XN401110 | x | 0 | 0 | 934 | XNK | 11 | 200 | 200 | C | LND |  | X | N | XN40 | 1110 | N | 11 | X | SS | LND | 1110 |  |  |  |  |  | SM |  |  |  |  |  |  |  |  |  |  |  |  |  |  |  |  |  |  |  |  |  |  |  |  |  |  |  |  |  |  |  |
|  | H | **HVAC** |  |  | 2012-03-17 | 2012-07-21 |  |  |  |  |  |  |  |  |  |  |  |  |  |  |  |  |  |  |  |  |  |  |  |  |  |  |  |  |  |  |  |  |  |  |  |  |  |  |  |  |  |  |  |  |  |  |  |  |  |  |  |  |  |  |  |  |  |  |  |  |  |  |  |  |  |  |  |  |  |
| XH00111005 |  | CA11 ComprBldg - Installation HVAC |  | 60d | 2012-03-17 | 2012-05-29 | XC501110 SS, P3H01SB (other project), EH30111005 (other project), XH000000 FF, XC501110_1 |  | 17.5d | 0d |  |  | HVAC - Compressor Building CA11 [7475 mhr]; HVAC - Compressor building CA11 [7475 h] |  |  | 7475,00 | XH00111005 |  | 7475 | 0 | 934 |  | 11 | 200 | 200 | C | LND | D | X | H | XH00 | 1110 | H | 11 | X | hvac | LND | 1110 |  | 2011-05-20 | 2011-08-15 |  |  | ARMO |  | x | REL XC50 | 2011-06-21 | 2011-09-05 |  |  |  |  |  |  |  |  |  |  |  |  |  |  |  |  |  |  |  |  |  |  |  |  |  |  |
| XH00111010 |  | CA11 ComprBldg - Testing/Commissioning HVAC (Start w. temp. Power) |  | 60d | 2012-05-11 | 2012-07-21 | XH00111006 FS-15d, X0300080, X0300008 FS+20d, X0300060, XH000C10, XH00111005 FS-15d |  | 29.5d | 0d |  |  |  |  |  |  | XH00111010 |  | 0 | 0 | 934 |  | 11 | 200 | 200 | C | LND |  | X | H | XH20 | 1110 | H | 11 | X | hvac | LND | 1110 |  |  |  |  |  | ARMO |  |  |  | 2011-09-05 | 2011-11-21 |  |  |  |  |  |  |  |  |  |  |  |  |  |  |  |  |  |  |  |  |  |  |  |  |  |  |
| XH00111007 |  | CA11 ComprBldg - HVAC ready for Heating | milestone | 0d | 2012-05-23 | 2012-05-23 | XH00111010 SS+10d |  | 264d | 80d |  |  |  |  |  |  | XH00111007 |  | 0 | 0 | 934 |  | 11 | 200 | 200 | C | LND | D | X | H | XH00 | 1110 | H | 11 | X | hvac | LND | 1110 |  |  |  | CM01 |  | ARMO |  |  |  | 2011-09-16 | 2011-09-16 |  |  |  |  |  |  |  |  |  |  |  |  |  |  |  |  |  |  |  |  |  |  |  |  |  |  |
| XH00111006 |  | CA11 ComprBldg - Installation HVAC finished | milestone | 0d | 2012-05-29 | 2012-05-29 | XH00111005 FF |  | 29.5d | 0d |  |  |  |  |  |  | XH00111006 |  | 0 | 0 | 934 |  | 11 | 200 | 200 | C | LND | D | X | H | XH00 | 1110 | H | 11 | X | hvac | LND | 1110 |  | 2011-08-15 | 2011-08-15 | CM01 |  | ARMO |  |  | REL XC50 | 2011-09-05 | 2011-09-05 |  |  |  |  |  |  |  |  |  |  |  |  |  |  |  |  |  |  |  |  |  |  |  |  |  |  |
|  | U | **Package Units** |  |  |  |  |  |  |  |  |  |  |  |  |  |  |  |  |  |  |  |  |  |  |  |  |  |  |  |  |  |  |  |  |  |  |  |  |  |  |  |  |  |  |  |  |  |  |  |  |  |  |  |  |  |  |  |  |  |  |  |  |  |  |  |  |  |  |  |  |  |  |  |  |  |
|  | B | **Mechanical - Stationary Equipment** |  |  | 2011-10-25 | 2012-05-29 |  |  |  |  |  |  |  |  |  |  |  |  |  |  |  |  |  |  |  |  |  |  |  |  |  |  |  |  |  |  |  |  |  |  |  |  |  |  |  |  |  |  |  |  |  |  |  |  |  |  |  |  |  |  |  |  |  |  |  |  |  |  |  |  |  |  |  |  |  |
| XB001110 |  | CA11 ComprBldg - Overhead Crane / Static Equipment | level of effort | 175.5d | 2011-10-25 | 2012-05-29 |  |  | -117.5d | 0d |  |  |  |  |  | 9 | XB001110 |  | 0 | 0 | 934 | XBB | 11 | 200 | 200 | C | LND | D | X | B | XB00 | 1110 | B | 11 | X | EQ | LND | 1110 |  |  |  |  |  |  |  |  |  | 2011-06-07 | 2011-07-12 |  |  |  |  |  |  |  |  |  |  |  |  |  |  |  |  |  |  |  |  |  |  |  |  |  |  |
|  | M | **Mechanical - Rotating Equipment** |  |  | 2011-12-15 | 2012-03-26 |  |  |  |  |  |  |  |  |  |  |  |  |  |  |  |  |  |  |  |  |  |  |  |  |  |  |  |  |  |  |  |  |  |  |  |  |  |  |  |  |  |  |  |  |  |  |  |  |  |  |  |  |  |  |  |  |  |  |  |  |  |  |  |  |  |  |  |  |  |
| K-21301 |  | OFFGAS COMPRESSOR |  | 25d | 2011-12-15 | 2012-01-19 | XM101110 SS, XC911110, XC20111010, P3M03S1 (other project), P3B160 (other project), XC20111010 FF, ER291100 (other project), XN201110 |  | -163d | 0d |  |  | Rotating Equipment (w/ lube oil unit) [32.29 t]; Rotating equipment (w/ lube oil unit) [2738.75 h] | 129,160 |  | 2738,75 | K-21301 |  | 2738,75 | 0 |  |  | 11 |  |  |  |  | EQ | X | M |  | 1110 |  |  |  |  |  |  |  |  |  | E-08-01-05 |  | SEM |  |  |  |  |  | 31,3 | 12000 | concrete +0.00 | 2DC 8460 / 6 | K-21301 | SK1110 | 2010-05-31 | 2010-11-30 | 2010-12-15 | 2011-04-01 | 1224/1235-1246 | M03 OFFGAS COMPRESSOR (K-21-/22301) | Burckhardt | 034 | 2012-01-20 | 2011-11-01 |  |  |  |  |  |  |  |  |  |  |
| XM101110 |  | CA11 ComprBldg - Install Offgas Compressor | level of effort | 80d | 2011-12-15 | 2012-03-26 | K-22301 FF |  | -86d | 0d |  |  |  |  |  | 63 | XM101110 |  | 0 | 0 | 934 | XBB | 11 | 200 | 200 | C | LND |  | X | M | XM10 | 1110 | M | 11 | X | EQ | LND | 1110 |  | 2011-04-20 | 2011-07-30 | E-08-01-05 |  |  | 2DC8460 |  |  | 2011-06-20 | 2011-09-03 |  |  |  |  |  |  |  |  |  |  |  |  | Burckhardt | 034 | 2012-01-20 | 2011-11-01 | E-08-01-05 | UDF_G1 | 2011-06-25 | 2011-10-06 |  |  |  |  |  |  |
| K-22301 |  | OFFGAS COMPRESSOR |  | 25d | 2012-01-20 | 2012-02-17 | XC911110, K-21301 SS+25d, P3B160 (other project), XC20111010 FF, XC20111010, P3M03S1 (other project), ER291100 (other project), XN201110 |  | -113d | 1d |  |  | Rotating equipment (w/ lube oil unit) [2738.75 h]; Rotating Equipment (w/ lube oil unit) [32.29 t] | 129,160 |  | 2738,75 | K-22301 |  | 2738,75 | 0 |  |  | 11 |  |  |  |  | EQ | X | M |  | 1110 |  |  |  |  |  |  |  |  |  | E-08-01-05 |  | SEM |  |  |  |  |  | 31,3 | 12000 | concrete +0.00 | 2DC 8460 / 6 | K-22301 | SK1110 | 2010-05-31 | 2010-11-30 | 2010-12-15 | 2011-04-01 | 1224/1235-1246 | M03 OFFGAS COMPRESSOR (K-21-/22301) | Burckhardt | 034 | 2012-01-20 | 2011-11-01 |  |  |  |  |  |  |  |  |  |  |
|  | R | **Piping** |  |  |  |  |  |  |  |  |  |  |  |  |  |  |  |  |  |  |  |  |  |  |  |  |  |  |  |  |  |  |  |  |  |  |  |  |  |  |  |  |  |  |  |  |  |  |  |  |  |  |  |  |  |  |  |  |  |  |  |  |  |  |  |  |  |  |  |  |  |  |  |  |  |
|  | E | **Electrical** |  |  | 2010-09-18 | 2012-09-12 |  |  |  |  |  |  |  |  |  |  |  |  |  |  |  |  |  |  |  |  |  |  |  |  |  |  |  |  |  |  |  |  |  |  |  |  |  |  |  |  |  |  |  |  |  |  |  |  |  |  |  |  |  |  |  |  |  |  |  |  |  |  |  |  |  |  |  |  |  |
| XC911110 |  | CA11 ComprBldg - Install Earthing System_CIVIL |  | 41d | 2010-09-18 A | 2010-11-08 A | XC20111005 FF+5d, EE901110 (other project) | 100% |  |  |  | TB26 - V - Construct-Winter partly * | Grounding & Lightning [360 pcs]; Grounding & Lightning [4050 h] | 162,000 | 162,000 | 4050,00 | XC911110 |  | 4050 | 4050 | 934 |  | 11 | 200 | 200 | C | LND |  | X | C | XE91 | 1110 | C | 11 | X | EA | LND | 1110 |  |  |  |  |  | MO11 |  |  |  |  |  |  |  |  |  |  |  |  |  |  |  |  |  |  |  |  |  |  |  |  |  |  |  |  |  |  |  |
| XR201110 |  | CA11 ComprBldg - Piping Prefabrication |  | 90d | 2011-12-15 | 2012-04-06 | ER491110 (other project) FS+12d, XR500C00 FS+15d |  | -163d | 0d | as late as possible |  | A/G piping prefabrication [3300 Fpi]; A/G Piping (Prefab) [12375 h] | 6,688.75 |  | 12375,00 | XR201110 |  | 12375 | 0 | 934 |  | 11 | 200 | 200 | C | LND |  | X | R | XR20 | 1110 | R | 11 | X | PRP | LND | 1110 |  |  |  |  |  |  |  |  |  | 2011-02-17 | 2011-06-30 |  |  |  |  |  |  |  |  |  |  |  |  |  |  |  |  |  |  |  |  |  |  |  |  |  |  |
| XR401110 |  | CA11 ComprBldg - Piping Installation |  | 100d | 2012-01-26 | 2012-05-25 | P3R03AS1 (other project) FF, P3R04S1 (other project) FF+20d, P3J02S (other project) FF, P3J04IS (other project), K-21301 SS+30d, P3J01AS (other project), P3R03BS1 (other project) FF, P3R07BS (other project) FF+30d, P3S07S (other project) FF+20d, P3R09BS (other project) FF+20d, P3S06S (other project), P3J04CS1 (other project), K-22301 FF+30d, XR201110 SS+30d, P3R07AS1 (other project) FF+20d |  | -163d | 0d |  |  | A/G piping field installation [4040 Fpi]; Control & Shut-off valves [26 pcs]; Install Control & Shut-off Valves [136.5 h]; A/G Piping (Field) [25250 h]; Deluge Piping [500 Fpi]; Deluge piping [3125 h] | 154,243.85 |  | 28511,50 | XR401110 |  | 28511,5 | 0 | 934 |  | 11 | 200 | 200 | C | LND |  | X | R | XR40 | 1110 | R | 11 | X | PI | LND | 1110 |  | 2011-03-01 | 2011-11-20 | E-06-03-02 |  |  | 2DC8460 |  |  | 2011-07-25 | 2011-11-07 |  |  |  |  |  |  |  |  |  |  |  |  |  |  |  |  | E-06-03-02 | UDF_G1 | 2011-07-30 |  |  |  |  |  |  |  |
| XE911115 |  | CA11 ComprBldg - Install Earthing System_E/I |  | 10d | 2012-03-07 | 2012-03-21 | XN301110, XN201110, K-21301, K-22301 |  | 82d | 174.5d |  | TB26 - V - Construct-Winter partly * |  |  |  | 400 | XE911115 |  | 0 | 0 | 934 |  | 11 | 200 | 200 | C | LND |  | X | E | XE91 | 1110 | E | 11 | X | EA | LND | 1110 |  | 2011-05-10 | 2011-11-30 | E-16-07-01 |  | URMA |  |  |  |  |  |  |  |  |  |  |  |  |  |  |  |  |  |  |  | 2012-05-10 | 2011-09-20 |  |  |  |  | UDF_G3 |  |  |  |  |  |
| XE401110 |  | CA11 ComprBldg - Install Cable Trays |  | 30d | 2012-03-27 | 2012-04-30 | EE46111010 (other project), EE46510120 (other project) FF, XR401110 SS+50d, P3E16S (other project), XN201110, XN801110 |  | -163d | 0d |  |  | Cable trays/conduits [380 m]; Cable trays [1140 h] | 45,600 |  | 1140,00 | XE401110 | x | 1140 | 0 | 934 |  | 11 | 200 | 200 | C | LND |  | X | E | XE40 | 1110 | E | 11 | X | EL | LND | 1110 |  | 2011-05-20 | 2011-08-20 | E-15-01-07 | m | URMA | 2DC8460 |  |  |  |  |  |  |  |  |  |  |  |  |  |  |  |  |  |  | 2011-11-30 | 2011-09-20 |  |  |  |  | UDF_G3 | 800 | 2011-08-27 | 2011-11-05 |  |  |
| XE701110 |  | CA11 ComprBldg - Install Lighting & Small Power |  | 50d | 2012-05-02 | 2012-06-30 | XN801110, XE401110, XP341610 FS+50d, EE761110 (other project), P3E09S (other project), EE76111010 (other project), XH00111005 SS+20d, XC501110_1 |  | 0d | 2.5d |  | TB26 - V - Construct-Winter partly * | Cable Pulling [2100 m]; Lighting illuminates [210 pcs]; Lighting (iluminates) [2100 h]; Cable pulling [1050 h] | 126,000 |  | 3150,00 | XE701110 |  | 3150 | 0 | 934 |  | 11 | 200 | 200 | C | LND |  | X | E | XE70 | 1110 | E | 11 | X | EL | LND | 1110 |  | 2011-05-10 | 2012-01-31 | E-16-03-01 |  | URMA |  | x |  |  |  |  |  |  |  |  |  |  |  |  |  |  |  |  |  | 2012-05-10 | 2011-08-15 |  |  |  |  | UDF_G3 |  |  |  |  |  |
| XR601110 |  | CA11 ComprBldg - Piping Pressure Tests |  | 40d | 2012-05-02 | 2012-06-19 | XR401110 FF+20d, XR605201 FF |  | -70d | 0d |  |  |  |  |  | 803 | XR601110 |  | 0 | 0 | 934 |  | 11 | 200 | 200 | C | LND |  | X | R | XR60 | 1110 | R | 11 | X | HY | LND | 1110 |  | 2011-03-01 | 2011-11-20 | E-06-03-02 |  |  | 2DC8460 |  |  |  |  |  |  |  |  |  |  |  |  |  |  |  |  |  |  |  |  | E-06-03-02 | UDF_G1 |  |  |  |  |  |  |  |  |
| XE341110 |  | CA11 ComprBldg - Install Local Operation Panels |  | 20d | 2012-05-29 | 2012-06-22 | XE401110, EE46111010 (other project), K-22301, K-21301, V-22320, V-21320, HO-21001, HO-21003, XR401110 SS+50d |  | -65.5d | 0d |  |  | Field Panels [11 pcs]; Field panels [220 h] | 8,800 |  | 220,00 | XE341110 |  | 220 | 0 | 934 |  | 11 | 200 | 200 | C | LND |  | X | E | XE34 | 1110 | E | 11 | X | EL | LND | 1110 |  | 2011-05-10 | 2011-11-30 | E-16-07-01 |  | URMA | 2DC8460 |  |  |  |  |  |  |  |  |  |  |  |  |  |  |  |  |  |  | 2012-05-10 | 2011-09-20 |  |  |  |  | UDF_G3 |  |  |  |  |  |
| XE501110 |  | CA11 ComprBldg - Cable Pulling Electric |  | 50d | 2012-05-29 | 2012-07-27 | XE401110, XE505201 SS+5d, XE500C01, P3E15AS (other project), P3E15CS (other project), P3E15BS (other project), EE561110 (other project), XE405401, XE405201, XE505401 SS+10d |  | -60.5d | 5d |  | TB26 - V - Construct-Winter partly * | Cable Pulling [9200 m]; Cable pulling [4600 h] | 184,000 |  | 4600,00 | XE501110 |  | 4600 | 0 | 934 |  | 11 | 200 | 200 | C | LND |  | X | E | XE50 | 1110 | E | 11 | X | EL | LND | 1110 |  | 2011-05-20 | 2012-02-10 | E-16-01-01 | m | URMA | 2DC8460 |  |  |  |  |  |  |  |  |  |  |  |  |  |  |  |  |  |  | 2012-07-01 | 2011-10-01 |  |  |  |  | UDF_G3 | 9500 | 2011-11-07 | 2012-02-28 |  |  |
| XE801110 |  | CA11 ComprBldg - Install Heat Tracing |  | 50d | 2012-06-07 | 2012-08-04 | XW501110 FF+20d, K-22301, E3E1950 (other project), K-21301, P3E19S (other project), XE800C00 SS, XR401110, XR601110 FF+20d |  | -30d | 0d |  | TB26 - V - Construct-Winter partly * | Electrical Heat Tracing [4500 m]; Electrical heat tracing [2250 h] | 90,000 |  | 2250,00 | XE801110 |  | 2250 | 0 | 934 |  | 11 | 200 | 200 | C | LND |  | X | E | XE80 | 1110 | E | 11 | X | HT | LND | 1110 |  | 2011-06-20 | 2012-03-20 | E-16-04-01 |  | URMA | 2DC8460 |  |  |  |  |  |  |  |  |  |  |  |  |  |  |  |  |  | 005 | 2012-06-30 | 2011-09-15 |  |  |  |  | UDF_G3 |  |  |  |  |  |
| XR801110 |  | CA11 ComprBldg - Piping Reinstatement |  | 20d | 2012-06-07 | 2012-06-30 | IMS-C-000360 FF, XR601110 FF+10d |  | -70d | 0d |  |  |  |  |  | 401 | XR801110 |  | 0 | 0 | 934 |  | 11 | 200 | 200 | C | LND |  | X | R | XR80 | 1110 | R | 11 | X | PI | LND | 1110 |  | 2011-03-01 | 2011-11-20 | E-06-03-02 |  |  | 2DC8460 |  |  |  |  |  |  |  |  |  |  |  |  |  |  |  |  |  |  |  |  | E-06-03-02 | UDF_G1 |  | 2012-01-28 |  |  |  |  |  |  |
| XE601110 |  | CA11 ComprBldg - Cable Termination & Testing |  | 50d | 2012-06-22 | 2012-08-20 | XE501110 FF+15d, XE341110, HO-21001, HO-21003, V-21320, V-22320, K-21301, K-22301 |  | -65.5d | 2d |  | TB26 - V - Construct-Winter partly * | Cable connecting [260 pcs]; Cable connecting [650 h] | 26,000 |  | 650,00 | XE601110 |  | 650 | 0 | 934 |  | 11 | 200 | 200 | C | LND |  | X | E | XE60 | 1110 | E | 11 | X | ET | LND | 1110 |  | 2011-04-20 | 2011-11-30 | E-16-02-01 |  | URMA | 2DC8460 |  |  |  |  |  |  |  |  |  |  |  |  |  |  |  |  |  |  | 2012-08-14 | 2011-12-10 |  |  |  |  | UDF_G3 |  |  |  |  |  |
| XE921110 |  | CA11 ComprBldg - Install Fire Detection System |  | 60d | 2012-07-04 | 2012-09-12 | XH00111005, XJ421110, XC501110, XE701110 |  | 170d |  |  | TB26 - V - Construct-Winter partly * | Fire Detection System; Fire detection system |  |  | 0,00 | XE921110 | x | 0 | 0 | 934 |  | 11 | 200 | 200 | C | UIO |  | X | E | XE92 | 1110 | E | 11 | X | FGDS | LND | 1110 |  |  |  |  |  |  |  | x |  |  |  |  |  |  |  |  |  |  |  |  |  |  |  |  |  |  |  |  |  |  |  |  |  |  |  | 2011-12-09 | 2012-05-18 |
| XE961110 |  | CA11 ComprBldg - Install Communication System |  | 60d | 2012-07-04 | 2012-09-12 | XE701110, XJ421110, P3E13S (other project), XC501110, XH00111005 |  | 170d |  |  | TB26 - V - Construct-Winter partly * | Communication System |  |  | 0,00 | XE961110 | x | 0 | 0 | 934 |  | 11 | 200 | 200 | C | LND |  | X | E | XE96 | 1110 | E | 11 | X | CS | LND | 1110 |  |  |  |  |  |  |  | x |  |  |  |  |  |  |  |  |  |  |  |  |  |  |  |  |  |  |  |  |  |  |  |  |  |  |  | 2011-12-09 | 2012-05-18 |

Notes:
- XN711101: Scope: 09.02.2011: weight: 95 ton
- XN711105: Scope: 09.02.2011: weight: 20 ton
- XN201110: P3 Activity Log Info: Clarification Crane Installation
- XH00111010: Current Status: 21.01.2011 - Siegel - Vorgдnger zur IBN HVAC / Condensat, LP-Dampf, Kьhlwasser von FF + 30 Tage Lag auf FS + 0 geдndert!
- XM101110: Current Status: 17.01.2011 (Siegel): die Verschiebungen ergeben sich als Folge der / Verschiebung des Civil-Teils: Precast Concrete Elements vom 03-Dez-10 auf den / 19-Feb-11. Direkter Treiber ist die Fassade.
- XR401110: P3 Activity Log Info: Start with Fire Water System / Current Status: 17.01.2011 (Siegel): zurьckzurьhren auf die Verspдtete "Install Offgas / Compressor", was wiederum auf die Verschiebungen von Civil / basieren.
- XE801110: Scope: einige Teile sind mit ET (heat insulation with electrical / tracing)
- XE921110: Scope: FDS - 15 sensors / GDS - 17 sensors / DS + SAME
- XE961110: Scope: FDS - 15 sensors / GDS - 17 sensors / DS + SAME

| ID | WBS | Activity | Type | Duration | Start | Finish | Predecessors | Complete | Total float | Free float | Constraint | Calendar | Resources | Cost | TB26 Ressource Budget | UDF_CONTRACT START DATE | UDF_CONTRACT FINISH DATE | UDF_CONTRACT ITEM | UDF_CONTRACT INDICATOR | UDF_CONTRACT FINISH DATE REV1 | UDF_CONTRACT START DATE REV1 | UDF_SAVE ACT ID | UDF_CHECK BASELINE | UDF_BUDGETED LABOR UNIT | UDF_ACTUAL LABOR UNIT | Department | Constr. Area | PMT-Area | PMT-Schedule Org | PMT-Phase | PMT-Respons. | WBS Phase | WBS Discipline | WBS Type of Work | WBS Objects | Russia WBS Discipline (Russia) | Russia Construction Area | Russia WBS Phase | IMS | UPT | Russia WBS Objects | Subcontractor | Inquiry/Order No | Filter | TB26 Semantics | TB26 Material Res Values | UDF_ELECTRICAL START | UDF_ELECTRICAL FINISH | UDF_CONTRACT DATE PENALIZED | UDF_PENALIZED FINISH | UDF_EXPECTED START | UDF_EXPECTED FINISH | UDF_Concrete | Type of Work | Zeigen/n. Zeigen | Comments | UDF_SELECT UPDATE PROGRESS | 4 week lookahead |
| --- | --- | --- | --- | --- | --- | --- | --- | --- | --- | --- | --- | --- | --- | --- | --- | --- | --- | --- | --- | --- | --- | --- | --- | --- | --- | --- | --- | --- | --- | --- | --- | --- | --- | --- | --- | --- | --- | --- | --- | --- | --- | --- | --- | --- | --- | --- | --- | --- | --- | --- | --- | --- | --- | --- | --- | --- | --- | --- |
|  | J | **Instrumentation** |  |  | 2012-03-27 | 2012-11-13 |  |  |  |  |  |  |  |  |  |  |  |  |  |  |  |  |  |  |  |  |  |  |  |  |  |  |  |  |  |  |  |  |  |  |  |  |  |  |  |  |  |  |  |  |  |  |  |  |  |  |  |  |
| XJ321110 |  | CA11 ComprBldg SK1100 - Install Junction Boxes |  | 40d | 2012-03-27 | 2012-05-14 | K-21301, EJ321110 (other project), XM101110, P3J06ES (other project) FS+14d, K-22301, P3J06FS (other project) FF, XR401110 SS+50d |  | -86d | 12.5d |  |  | Junction Boxes/Cabinets/Panels [67 pcs]; Install Junction Boxes/ Cabinets/ Panels [1675 h] | 67,000 | 1675,00 | 2011-05-10 | 2012-02-20 | E-17-04-01 | UDF_G3 | 2012-07-20 | 2011-09-10 | XJ321110 | x | 1675 | 0 | 934 | 11 | 200 | 200 | C | LND | X | J | XJ32 | 1110 | J | 11 | X | IN | LND | 1110 | URMA |  |  |  |  |  |  |  |  |  |  |  |  |  |  |  |  |
| XJ301110 |  | CA11 ComprBldg - Install Field Instruments |  | 50d | 2012-05-29 | 2012-07-27 | P3J05S (other project), P3J12AS (other project), P3J07CS (other project), P3J07BS (other project), EJ360010 (other project), XR801110 FF, P3J04AS (other project), P3J04BS (other project), EJ361110 (other project), XR401110 SS+50d, HO-21001, HO-21003, V-21320, V-22320, K-21301, K-22301 |  | -92.5d | 0d |  | TB26 - V - Construct-Winter partly * | Field Instruments [105 pcs]; Install field instruments [577 h] | 23,100 | 577,00 | 2011-05-10 | 2012-02-20 | E-17-04-01 | UDF_G3 | 2012-07-20 | 2011-09-10 | XJ301110 |  | 577 | 0 | 934 | 11 | 200 | 200 | C | LND | X | J | XJ30 | 1110 | J | 11 | X | IN | LND | 1110 | URMA | 2DC8460 |  |  |  |  |  |  |  |  |  |  |  |  |  |  |  |
| XJ421110 |  | CA11 ComprBldg - Install Secondary Cable Trays |  | 30d | 2012-05-29 | 2012-07-04 | EJ46111010 (other project), XR401110 SS+50d, XE401110 FF, XJ321110 FF+14d, HO-21001, HO-21003, V-21320, V-22320, K-21301, K-22301 |  | -83.5d | 0d |  |  | Secondary cable trays [570 m]; Install secondary cable trays [2137.5 h] | 85,500 | 2137,50 | 2011-05-20 | 2011-08-20 | E-15-01-07 |  | 2011-11-30 | 2011-09-20 | XJ421110 | x | 2137,5 | 0 | 934 | 11 | 200 | 200 | C | LND | X | J | XJ42 | 1110 | J | 11 | X | IN | LND | 1110 | URMA |  | x | m | 840 | 2011-08-27 | 2011-11-05 |  |  |  |  |  |  |  |  |  |  |
| XJ441110 |  | CA11 ComprBldg - Install Conduits to Instrm |  | 30d | 2012-05-29 | 2012-07-04 | XJ321110, XE401110, XR401110 SS+50d, HO-21001, HO-21003, V-21320, V-22320, K-21301, K-22301 |  | -82.5d | 0d |  | TB26 - V - Construct-Winter partly * |  |  |  | 2011-05-10 | 2012-02-20 | E-17-04-01 |  | 2012-07-20 | 2011-09-10 | XJ441110 |  | 0 | 0 | 934 | 11 | 200 | 200 | C | LND | X | J | XJ44 | 1110 | J | 11 | X | IN | LND | 1110 | URMA |  |  |  |  |  |  |  |  |  |  |  |  |  |  |  |  |
| XJ521110 |  | CA11 ComprBldg - Pulling Multicore Cables |  | 60d | 2012-05-31 | 2012-08-10 | XJ321110 SS+20d, XJ525201 SS+10d, XE500C01, XE401110, XJ525401 SS+12d |  | -67.5d | 0d |  | TB26 - V - Construct-Winter partly * | Multicore cables [7200 m]; Pull multicore cables [3600 h] | 144,000 | 3600,00 | 2011-05-20 | 2012-03-10 | E-17-01-01 |  | 2012-06-16 | 2011-11-01 | XJ521110 |  | 3600 | 0 | 934 | 11 | 200 | 200 | C | LND | X | J | XJ52 | 1110 | J | 11 | X | IN | LND | 1110 | URMA |  |  | m | 5200 | 2011-10-18 | 2012-02-15 |  |  |  |  |  |  |  |  |  |  |
| XJ621110 |  | CA11 ComprBldg - Termin Multicore Cables |  | 50d | 2012-06-25 | 2012-08-22 | XJ521110 FF+10d, XJ321110 |  | -67.5d | 0d |  | TB26 - V - Construct-Winter partly * | Termination Field [1765 mhr]; Termination field [1765 h] | 176,500 | 1765,00 | 2011-05-20 | 2012-03-10 | E-17-01-01 |  | 2012-06-16 | 2011-11-01 | XJ621110 |  | 1765 | 0 | 934 | 11 | 200 | 200 | C | LND | X | J | XJ62 | 1110 | J | 11 | X | IN | LND | 1110 | URMA |  |  |  |  |  |  |  |  |  |  |  |  |  |  |  |  |
| XJ391110 |  | CA11 ComprBldg - Install Earthing Field Eqpt |  | 30d | 2012-07-04 | 2012-08-08 | XJ301110 FF+10d, XJ421110, XJ441110 |  | -82.5d | 10d |  | TB26 - V - Construct-Winter partly * |  |  |  | 2011-05-10 | 2012-02-20 | E-17-04-01 | UDF_G3 | 2012-07-20 | 2011-09-10 | XJ391110 |  | 0 | 0 | 934 | 11 | 200 | 200 | C | LND | X | J | XJ39 | 1110 | J | 11 | X | IN | LND | 1110 | URMA |  |  |  |  |  |  |  |  |  |  |  |  |  |  |  |  |
| XJ541110 |  | CA11 ComprBldg - Pulling Singlecore Cables |  | 50d | 2012-07-04 | 2012-08-31 | EJ801110 (other project), XJ441110 SS, XJ301110 FF+15d, XE500C01, XJ421110 |  | -62.5d | 30d |  | TB26 - V - Construct-Winter partly * | Singlecore cables [9900 m]; Pull singlecore cables [7425 h] | 297,000 | 7425,00 | 2011-05-10 | 2012-02-20 | E-17-04-01 |  | 2012-07-20 | 2011-09-10 | XJ541110 |  | 7425 | 0 | 934 | 11 | 200 | 200 | C | LND | X | J | XJ54 | 1110 | J | 11 | X | IN | LND | 1110 | URMA | 2DC8460 |  | m | 9513 | 2011-12-05 | 2012-03-21 |  |  |  |  |  |  |  |  |  |  |
| XJ701110 |  | CA11 ComprBldg - Instrument Tubing |  | 30d | 2012-07-16 | 2012-08-20 | XJ301110 FF+20d, XR401110 |  | -92.5d | 0d |  | TB26 - V - Construct-Winter partly * |  |  |  | 2011-05-10 | 2012-02-20 | E-17-04-01 |  | 2012-07-20 | 2011-09-10 | XJ701110 |  | 0 | 0 | 934 | 11 | 200 | 200 | C | LND | X | J | XJ70 | 1110 | J | 11 | X | IN | LND | 1110 | URMA |  |  |  |  |  |  |  |  |  |  |  |  |  |  |  |  |
| XJ641110 |  | CA11 ComprBldg - Termin Singlecore Cables |  | 50d | 2012-08-20 | 2012-10-17 | XJ541110 FF+10d, XJ301110, XJ321110, XJ391110, XJ701110 |  | -92.5d | 0d |  |  | Termination Field [1765 mhr]; Termination field [1765 h] | 176,500 | 1765,00 | 2011-05-10 | 2012-02-20 | E-17-04-01 |  | 2012-07-20 | 2011-09-10 | XJ641110 |  | 1765 | 0 | 934 | 11 | 200 | 200 | C | LND | X | J | XJ64 | 1110 | J | 11 | X | IN | LND | 1110 | URMA | 2DC8460 |  |  |  |  |  |  |  |  |  |  |  |  |  |  |  |
| XJ801110 |  | CA11 ComprBldg - Inspections/ Mech. Acceptance/ Loop Checks |  | 70d | 2012-08-22 | 2012-11-13 | X030410030 FS-20d, X3J100 FF, XJ391110 SS+10d, XJ701110 SS, X3J120 FS-40d, XJ641110 FF+20d, XE601110, XJ621110 |  | -67.5d | 0d |  | TB26 - V - Construct-Winter partly * | Loop Checks [300 pcs]; Loop checks [1500 h] | 60,000 | 1500,00 | 2011-06-10 | 2012-04-30 | E-17-02-01 |  | 2012-08-18 | 2012-03-01 | XJ801110 |  | 1500 | 0 | 934 | 11 | 200 | 200 | C | LND | X | J | XJ80 | 1110 | J | 11 | X | LT | LND | 1110 | URMA | 2DC8460 |  |  |  |  |  | x | 2012-08-18 |  |  |  |  |  |  |  |  |
|  | S | **Safety & Environment** |  |  |  |  |  |  |  |  |  |  |  |  |  |  |  |  |  |  |  |  |  |  |  |  |  |  |  |  |  |  |  |  |  |  |  |  |  |  |  |  |  |  |  |  |  |  |  |  |  |  |  |  |  |  |  |  |
|  | W | **Painting** |  |  | 2012-04-07 | 2012-07-12 |  |  |  |  |  |  |  |  |  |  |  |  |  |  |  |  |  |  |  |  |  |  |  |  |  |  |  |  |  |  |  |  |  |  |  |  |  |  |  |  |  |  |  |  |  |  |  |  |  |  |  |  |
| XW501110 |  | CA11 ComprBldg - Surf.Protection Piping |  | 80d | 2012-04-07 | 2012-07-12 | XR801110 FF+10d, XR201110 SS |  | -30d | 0d |  |  | Piping painting [1011 sqm]; Piping painting [2527 h] | 1,129.33 | 2527,00 |  |  |  |  |  |  | XW501110 |  | 2527 | 0 | 934 | 11 | 200 | 200 | C | LND | X | W | XW50 | 1110 | W | 11 | X | PA | LND | 1110 |  |  |  |  |  |  |  |  |  |  |  |  |  |  |  |  |  |
|  | V | **Insulation** |  |  | 2012-06-20 | 2012-09-26 |  |  |  |  |  |  |  |  |  |  |  |  |  |  |  |  |  |  |  |  |  |  |  |  |  |  |  |  |  |  |  |  |  |  |  |  |  |  |  |  |  |  |  |  |  |  |  |  |  |  |  |  |
| XV301110 |  | CA11 ComprBldg - Insulation Equipment |  | 80d | 2012-06-20 | 2012-09-20 | XV300C00 SS, XE801110 SS+10d |  | -28d | 0d |  | TB26 - V - Construct-Winter partly * | Equipment insulation [200 sqm]; Equipment insulation [2500 h] | 807.08 | 2500,00 |  | 2012-03-30 | E-13-03 |  |  |  | XV301110 |  | 2500 | 0 | 934 | 11 | 200 | 200 | C | LND | X | V | XV30 | 1110 | V | 11 | X | INS | LND | 1110 |  | 2DC8460 |  |  |  |  |  |  |  |  |  |  |  |  |  |  |  |
| XV501110 |  | CA11 ComprBldg - Insulation Piping |  | 80d | 2012-06-26 | 2012-09-26 | XR601110 SS+5d, XV301110 FF+5d, XE801110 FF+20d |  | -28d | 39.5d |  | TB26 - V - Construct-Winter partly * | Piping insulation [850 sqm]; Piping insulation [6375 h] | 3,222.42 | 6375,00 |  | 2012-04-30 | E-13-01 |  |  |  | XV501110 |  | 6375 | 0 | 934 | 11 | 200 | 200 | C | LND | X | V | XV50 | 1110 | V | 11 | X | INS | LND | 1110 |  | 2DC8460 |  |  |  |  |  |  |  |  |  |  |  |  |  |  |  |
|  | 11 | **CA11 - Offgas Compressor Filter Section** |  |  | 2011-02-08 | 2012-09-29 |  |  |  |  |  |  |  |  |  |  |  |  |  |  |  |  |  |  |  |  |  |  |  |  |  |  |  |  |  |  |  |  |  |  |  |  |  |  |  |  |  |  |  |  |  |  |  |  |  |  |  |  |
|  | C | **Civil Work** |  |  | 2011-05-10 | 2012-04-24 |  |  |  |  |  |  |  |  |  |  |  |  |  |  |  |  |  |  |  |  |  |  |  |  |  |  |  |  |  |  |  |  |  |  |  |  |  |  |  |  |  |  |  |  |  |  |  |  |  |  |  |  |
| XC201111 |  | CA11 OffgComprFilt SK1104 - Concrete Works Foundations |  | 6d | 2011-05-10 A | 2011-05-16 A | EC281111 (other project) FS+10d, XC200C10, EC45111105 (other project), XC20111010 FS-15d, XC151100 SS+63d | 100% |  |  |  | TB26 - V - Construct-Winter partly * | Concrete works [110 cbm]; Concrete works [3300 h] |  | 3300,00 |  |  |  |  |  |  | XC201111 |  | 3300 | 3300 | 934 | 11 | 200 | 200 | C | MO03 | X | C | XC20 | 1111 | C | 11 | X | mai | LND | 1111 | MO11 |  |  |  |  |  |  |  |  | 2011-04-28 | 2011-05-14 |  |  |  |  |  |  |
| XC801111 |  | CA11 ComprBldg SK1101 - Fire Proofing |  | 45d | 2011-11-24 | 2012-04-24 | IMS-C-000130 SS, XN801110 SS, IMS-C-000130 FF, XN201110 FS-10d, IMS-C-000135 |  | 55d | 147.5d |  | TB26 - T - Construct-Winter-3 (Dec/Jan/Feb free) * | Fire proofing [2250 sqm]; Fire proofing [16875 h] | 675,000 | 16875,00 |  |  |  |  |  |  | XC801111 |  | 16875 | 0 | 934 | 11 | 200 | 200 | C | CiC | X | C | XC80 | 1110 | C | 11 | X | FP | LND | 1110 | KRILAK |  |  |  |  |  |  |  |  |  |  | 1 |  |  |  |  |  |
|  | N | **Structural Steel** |  |  | 2011-02-08 | 2011-11-23 |  |  |  |  |  |  |  |  |  |  |  |  |  |  |  |  |  |  |  |  |  |  |  |  |  |  |  |  |  |  |  |  |  |  |  |  |  |  |  |  |  |  |  |  |  |  |  |  |  |  |  |  |
| XN701104 |  | CA11 OffgComprFilt SK1104 - KMD Assy Drawings | milestone | 0d | 2011-02-08 A | 2011-02-08 A |  | 100% |  |  | finish on 2011-02-08 | TB26 - V - Construct-Winter partly * |  |  | 22t |  |  |  |  |  |  | XN701104 | x | 0 | 0 | 934 | 11 | 200 | 200 | C | LND | X | N | XN05 | 1111 | N | 11 | X | SS | LND | 1111 |  | 999 |  |  |  |  |  |  |  |  |  |  | XNK | KMD |  |  |  |
| XN701100 |  | CA11 OffgComprFilt SK1100 - KMD Assy Drawings | milestone | 0d | 2011-04-22 A | 2011-04-22 A |  | 100% |  |  | finish on 2011-04-22 | TB26 - V - Construct-Winter partly * |  |  | 22t |  |  |  |  |  |  | XN701100 | x | 0 | 0 | 934 | 11 | 200 | 200 | C | LND | X | N | XN05 | 1111 | N | 11 | X | SS | LND | 1111 |  | 999 |  |  |  |  |  |  |  |  |  |  | XNK | KMD |  |  |  |
| XN711104 |  | CA11 OffgComprFilt SK1104 - Steel Deliveries | milestone | 0d | 2011-06-04 A | 2011-06-04 A |  | 100% |  |  | finish on 2011-05-08 | TB26 - 3 - Construction Normal 7days * CA17 |  |  | 22t |  |  |  |  |  |  | XN711104 |  | 0 | 0 | 934 | 11 | 200 | 200 | C | LND | X | N | XN06 | 1111 | N | 11 | X | SS | LND | 1111 |  | 999 |  |  |  |  |  |  |  |  |  |  | XNK | SD | 99% are on site |  |  |
| XN301111 |  | CA11 OffgComprFilt SK1104 - Install Primary Steel / Platforms |  | 20d | 2011-09-26 | 2011-10-18 | XN701104, P3N02*N (other project), XC201111, XN701100, XN711104 FS+10d, XN205201l FS-6d |  | 6d | 0d | start on or after 2011-09-05 | TB26 - V - Construct-Winter partly * | Piperacks, Main Structures [30 t]; Piperacks, Main structures [1275 h] | 1,448.61 | 1275,00 |  |  |  |  |  |  | XN301111 | x | 1275 | 0 | 934 | 11 | 200 | 200 | C | LND | X | N | XN30 | 1111 | N | 11 | X | SS | LND | 1111 | SM |  |  | t |  |  |  |  |  |  |  |  | XNK |  | Start 5.9. | 27.8. | x |
| XN401111 |  | CA11 OffgComprFilt SK1104 - Install Railings,Ladders,etc. |  | 15d | 2011-10-19 | 2011-11-07 | XN301111 SS+20d |  | 7d | 0d |  | TB26 - V - Construct-Winter partly * | Ladders & platforms [3 t]; Ladders & platforms [300 h] | 206.94 | 300,00 |  |  |  | UDF_G4 |  |  | XN401111 |  | 300 | 0 | 934 | 11 | 200 | 200 | C | LND | X | N | XN40 | 1111 | N | 11 | X | SS | LND | 1111 | SM |  |  |  |  |  |  |  |  |  |  |  | XNK |  |  |  |  |
| XN801111 |  | CA11 OffgComprFilt SK1104 - Install Cladding (roof cladding uninsulated) |  | 25d | 2011-10-19 | 2011-11-23 | XN301111 |  | 183d | 250.5d |  | TB26 - V - Construct-Winter partly * | Cladding [120 sqm]; Cladding [600 h] | 24,000 | 600,00 |  |  |  | UDF_G4 |  |  | XN801111 |  | 600 | 0 | 934 | 11 | 200 | 200 | C | LND | X | N | XN80 | 1111 | N | 11 | X | SS | LND | 1111 | SM |  |  |  |  |  |  |  |  |  |  |  | XNK |  |  |  |  |
| XN601111 |  | CA11 OffgComprFilt SK1104 - Install Gratings |  | 10d | 2011-10-25 | 2011-11-07 | PN691111 (other project), XN401111 FF |  | 7d | 3d |  | TB26 - V - Construct-Winter partly * | Grating [100 sqm]; Grating [375 h] | 8,019.1 | 375,00 |  |  |  |  |  |  | XN601111 |  | 375 | 0 | 934 | 11 | 200 | 200 | C | LND | X | N | XN60 | 1111 | N | 11 | X | SS | LND | 1111 | SM |  |  |  |  |  |  |  |  |  |  |  | XNK |  |  |  |  |

Notes:
- XW501110: P3 Activity Log Info: Clarification Surface Protection during Prefab
- XC801111: Current Status: 20110530 (O.Siegel): die / Vertragsverhandlung ist am 30.05.2011. Bis die Vertragliche Detail geklдrt / werden und die Firma MobilisierungsmaЯnahmen getroffen hat, wird es Mitte Juli / sein. / Scope: No. of beams/ columns: 398 (fire Resistance R90) / Length 1911,15m; Weight: 100383,01 kg; Surface Area 2219,5 / sqm
- XN711104: Scope: 09.02.2011: weight: 33 ton - Jan 19 ton; Feb 14 / ton
- XN301111: Scope: SK1100: die vier Platformen vor dem SK1104. / Current Status: 11.03.2011 (O.Siegel): nach Rьcksprache mit J. Soucek / (Civil) wurde das Startdatum fьr Steel Structure auf Anfang 3.Q gesetzt.
- XN801111: Scope: Metalpanels roof cladding uninsulated / ca. 120m2
- XN601111: Scope: Grating - 125m2

| ID | WBS | Activity | Type | Duration | Start | Finish | Predecessors | Complete | Total float | Free float | Constraint | Calendar | Resources | Cost | Actual cost | TB26 Ressource Budget | UDF_Weight (ton) | WEIGHT | UDF_TAG No | UDF_Object No | UDF_DELIVERY DATE DISPATCH PLANNED | UDF_DELIVERY DATE SITE NEED DATE | UDF_PACKAGE | UDF_SAVE ACT ID | UDF_BUDGETED LABOR UNIT | UDF_ACTUAL LABOR UNIT | Constr. Area | Zeigen/n. Zeigen | WBS Phase | WBS Discipline | WBS Objects | UDF_Text4 | UDF_CONTRACT ITEM | UDF_LEVEL | UDF_PO No | UDF_DELIVERY DATE PO | UDF_DELIVERY DATE TO SITE PLANNED | UDF_SUPPLIER | UDF_Vendor Representatives | UDF_CONTRACT FINISH DATE REV1 | UDF_CONTRACT START DATE REV1 | Subcontractor | Comments | Drawing Indicator | UDF_CONTRACT START DATE | UDF_CONTRACT FINISH DATE | Department | Type of Work | PMT-Area | PMT-Schedule Org | PMT-Phase | PMT-Respons. | WBS Type of Work | Russia WBS Discipline (Russia) | Russia Construction Area | Russia WBS Phase | IMS | UPT | Russia WBS Objects | UDF_PLANNED START | UDF_PLANNED FINISH | UDF_CONTRACT INDICATOR | TB26 Semantics | TB26 Material Res Values | UDF_ELECTRICAL START | UDF_ELECTRICAL FINISH | UDF_CHECK BASELINE | UDF_COMMENTS_0827 | Filter |
| --- | --- | --- | --- | --- | --- | --- | --- | --- | --- | --- | --- | --- | --- | --- | --- | --- | --- | --- | --- | --- | --- | --- | --- | --- | --- | --- | --- | --- | --- | --- | --- | --- | --- | --- | --- | --- | --- | --- | --- | --- | --- | --- | --- | --- | --- | --- | --- | --- | --- | --- | --- | --- | --- | --- | --- | --- | --- | --- | --- | --- | --- | --- | --- | --- | --- | --- | --- | --- | --- |
|  | H | **HVAC** |  |  |  |  |  |  |  |  |  |  |  |  |  |  |  |  |  |  |  |  |  |  |  |  |  |  |  |  |  |  |  |  |  |  |  |  |  |  |  |  |  |  |  |  |  |  |  |  |  |  |  |  |  |  |  |  |  |  |  |  |  |  |  |  |  |  |  |
|  | U | **Package Units** |  |  |  |  |  |  |  |  |  |  |  |  |  |  |  |  |  |  |  |  |  |  |  |  |  |  |  |  |  |  |  |  |  |  |  |  |  |  |  |  |  |  |  |  |  |  |  |  |  |  |  |  |  |  |  |  |  |  |  |  |  |  |  |  |  |  |  |
|  | B | **Mechanical - Stationary Equipment** |  |  | 2011-10-25 | 2011-11-11 |  |  |  |  |  |  |  |  |  |  |  |  |  |  |  |  |  |  |  |  |  |  |  |  |  |  |  |  |  |  |  |  |  |  |  |  |  |  |  |  |  |  |  |  |  |  |  |  |  |  |  |  |  |  |  |  |  |  |  |  |  |  |  |
| HO-21001 |  | OVERHEAD TRAVELLING CRANE |  | 10d | 2011-10-25 | 2011-11-05 | XC20111010, P3A12S3 (other project), XN201110 SS, XB001110 FF, XB001110 SS, ER291100 (other project) |  | 48d | 165.5d |  |  | Static Equipment < 10 tons [0.3 t]; Static equipment < 10t [30 h] | 1,200 |  | 30,00 | 0,3 | 8200 | HO-21001 | SK1101 | 2011-01-09 | 2011-02-01 | A12 OVERHEAD CRANES / TROLLEYS (incl. in Civil Subcontract) | HO-21001 | 30 | 0 | 11 | EQ | X | B | 1110 |  |  |  |  |  |  |  |  |  |  |  |  |  |  |  |  |  |  |  |  |  |  |  |  |  |  |  |  |  |  |  |  |  |  |  |  |  |  |
| HO-21003 |  | OVERHEAD TRAVELLING CRANE |  | 10d | 2011-10-25 | 2011-11-05 | XC20111010, P3A12S3 (other project), XN201110 SS, XB001110 SS, XB001110 FF, ER291100 (other project) |  | 48d | 165.5d |  |  | Static Equipment < 10 tons [8.2 t]; Static equipment < 10t [820 h] | 32,800 |  | 820,00 | 8,2 | 8200 | HO-21003 | SK1101 | 2011-01-09 | 2011-02-01 | A12 OVERHEAD CRANES / TROLLEYS (incl. in Civil Subcontract) | HO-21003 | 820 | 0 | 11 | EQ | X | B | 1110 |  |  |  |  |  |  |  |  |  |  |  |  |  |  |  |  |  |  |  |  |  |  |  |  |  |  |  |  |  |  |  |  |  |  |  |  |  |  |
| F-21302 |  | OFFGAS COMPRESSOR FILTERS |  | 10d | 2011-10-31 | 2011-11-11 | XB101111 SS, ER291100 (other project) FS+10d, XN301111 FS+10d, XC201111, IMS-C-000165 SS, P3A16S (other project), XB101111 FF |  | 7d | 0d |  |  | Static Equipment < 10 tons [2.8 t]; Static equipment < 10t [280 h] | 11,200 |  | 280,00 | 2,8 | 2800 | F-21302 | SK1111 | 2010-12-08 | 2011-02-10 | A16 OFFGAS COMPRESSOR FILTERS (F-21-/22302/3) | F-21302 | 280 | 0 | 11 | EQ | X | B | 1111 | MKG-40 | E-08-01-03 | structure +4.500 | 2 DC 8560 | 2010-10-30 | 2010-12-24 | Zeppelin | 026 | 2011-10-28 | 2011-10-17 | SEM |  |  |  |  |  |  |  |  |  |  |  |  |  |  |  |  |  |  |  |  |  |  |  |  |  |  |  |
| F-21303 |  | OFFGAS COMPRESSOR FILTERS |  | 10d | 2011-10-31 | 2011-11-11 | XB101111 FF, P3A16S (other project), ER291100 (other project) FS+10d, XN301111 FS+10d, XB101111 SS, IMS-C-000165 SS, XC201111 |  | 7d | 0d |  |  | Static Equipment < 10 tons [2.8 t]; Static equipment < 10t [280 h] | 11,200 |  | 280,00 | 2,8 | 2800 | F-21303 | SK1111 | 2010-12-08 | 2011-02-10 | A16 OFFGAS COMPRESSOR FILTERS (F-21-/22302/3) | F-21303 | 280 | 0 | 11 | EQ | X | B | 1111 | MKG-40 | E-08-01-03 | structure +4.500 | 2 DC 8560 | 2010-10-30 | 2010-12-24 | Zeppelin | 026 | 2011-10-28 | 2011-10-17 | SEM |  |  |  |  |  |  |  |  |  |  |  |  |  |  |  |  |  |  |  |  |  |  |  |  |  |  |  |
| F-22302 |  | OFFGAS COMPRESSOR FILTERS |  | 10d | 2011-10-31 | 2011-11-11 | XB101111 SS, IMS-C-000165 SS, ER291100 (other project) FS+10d, XC201111, XB101111 FF, P3A16S (other project), XN301111 FS+10d |  | 7d | 0d |  |  | Static Equipment < 10 tons [2.8 t]; Static equipment < 10t [280 h] | 11,200 |  | 280,00 | 2,8 | 2800 | F-22302 | SK1111 | 2010-12-08 | 2011-02-10 | A16 OFFGAS COMPRESSOR FILTERS (F-21-/22302/3) | F-22302 | 280 | 0 | 11 | EQ | X | B | 1111 | MKG-40 | E-08-01-03 | structure +4.500 | 2 DC 8560 | 2010-10-30 | 2010-12-24 | Zeppelin | 026 | 2011-10-28 | 2011-10-17 | SEM |  |  |  |  |  |  |  |  |  |  |  |  |  |  |  |  |  |  |  |  |  |  |  |  |  |  |  |
| F-22303 |  | OFFGAS COMPRESSOR FILTERS |  | 10d | 2011-10-31 | 2011-11-11 | XB101111 FF, ER291100 (other project) FS+10d, XB101111 SS, P3A16S (other project), XN301111 FS+10d, XC201111, IMS-C-000165 SS |  | 7d | 0d |  |  | Static Equipment < 10 tons [2.8 t]; Static equipment < 10t [280 h] | 11,200 |  | 280,00 | 2,8 | 2800 | F-22303 | SK1111 | 2010-12-08 | 2011-02-10 | A16 OFFGAS COMPRESSOR FILTERS (F-21-/22302/3) | F-22303 | 280 | 0 | 11 | EQ | X | B | 1111 | MKG-40 | E-08-01-03 | structure +4.500 | 2 DC 8560 | 2010-10-30 | 2010-12-24 | Zeppelin | 026 | 2011-10-28 | 2011-10-17 | SEM |  |  |  |  |  |  |  |  |  |  |  |  |  |  |  |  |  |  |  |  |  |  |  |  |  |  |  |
| XB101111 |  | CA11 OffgComprFilt - Install Static Eqpt | level of effort | 8d | 2011-10-31 | 2011-11-10 |  |  | 4d | 0d |  | TB26 - V - Construct-Winter partly * |  |  |  | 12t |  |  |  |  |  |  |  | XB101111 | 0 | 0 | 11 |  | X | B | 1111 |  | E-08-01-03 |  |  |  |  |  |  | 2011-10-28 | 2011-10-17 | SEM | E-08-01-06 | UDF_G3 | 2011-03-01 | 2011-03-30 | 934 | XBB | 200 | 200 | C | LND | XB10 | B | 11 | X | EQ | LND | 1111 |  |  |  |  |  |  |  |  |  |  |
|  | M | **Mechanical - Rotating Equipment** |  |  |  |  |  |  |  |  |  |  |  |  |  |  |  |  |  |  |  |  |  |  |  |  |  |  |  |  |  |  |  |  |  |  |  |  |  |  |  |  |  |  |  |  |  |  |  |  |  |  |  |  |  |  |  |  |  |  |  |  |  |  |  |  |  |  |  |
|  | R | **Piping** |  |  | 2011-09-17 | 2012-02-08 |  |  |  |  |  |  |  |  |  |  |  |  |  |  |  |  |  |  |  |  |  |  |  |  |  |  |  |  |  |  |  |  |  |  |  |  |  |  |  |  |  |  |  |  |  |  |  |  |  |  |  |  |  |  |  |  |  |  |  |  |  |  |  |
| XR201111 |  | CA11 OffgComprFilt - Piping Prefabrication |  | 50d | 2011-09-17 | 2011-11-15 | ER491111 (other project) FS+12d, XR500C00 FS+15d |  | 34d | 0d | start on or after 2011-09-17 |  | A/G piping prefabrication [800 Fpi]; A/G Piping (Prefab) [3000 h] | 3,344.37 |  | 3000,00 |  |  |  |  |  |  |  | XR201111 | 3000 | 0 | 11 |  | X | R | 1111 |  |  |  |  |  |  |  |  |  |  |  |  |  |  |  | 934 |  | 200 | 200 | C | LND | XR20 | R | 11 | X | PRP | LND | 1111 |  |  |  |  |  |  |  |  |  |  |
| XR401111 |  | CA11 OffgComprFilt - Piping Installation |  | 40d | 2011-11-12 | 2011-12-28 | XR201111 SS+20d, P3J04IS (other project), F-21303, F-22303, XN601111, F-22302, F-21302, P3J04CS1 (other project), IMS-C-000190 FF |  | 7d | 0d |  |  | A/G piping field installation [1010 Fpi]; Control & Shut-off valves [11 pcs]; Install Control & Shut-off Valves [57.75 h]; A/G Piping (Field) [6312.5 h] | 14,194.54 |  | 6370,25 |  |  |  |  |  |  |  | XR401111 | 6370,25 | 0 | 11 |  | X | R | 1111 |  | E-06-03-02 |  |  |  |  |  |  |  |  |  | E-06-03-02 | UDF_G3 | 2011-03-01 |  | 934 |  | 200 | 200 | C | LND | XR40 | R | 11 | X | PI | LND | 1111 | 2011-05-16 |  |  |  |  |  |  |  |  |  |
| XR601111 |  | CA11 OffgComprFilt - Piping Pressure Tests |  | 20d | 2011-12-29 | 2012-01-27 | XR600C00 SS, X0300020, XR401111 FF+20d |  | 68d | 0d |  |  |  |  |  | 201 |  |  |  |  |  |  |  | XR601111 | 0 | 0 | 11 |  | X | R | 1111 |  | E-06-03-02 |  |  |  |  |  |  |  |  |  | E-06-03-02 | UDF_G3 |  |  | 934 |  | 200 | 200 | C | LND | XR60 | R | 11 | X | HY | LND | 1111 |  |  |  |  |  |  |  |  |  |  |
| XR801111 |  | CA11 OffgComprFilt - Piping Reinstatement |  | 20d | 2012-01-17 | 2012-02-08 | XR601111 FF+10d, IMS-C-000360 FF |  | 68d | 10d |  |  |  |  |  | 101 |  |  |  |  |  |  |  | XR801111 | 0 | 0 | 11 |  | X | R | 1111 |  | E-06-03-02 |  |  |  |  |  |  |  |  |  | E-06-03-02 | UDF_G3 |  | 2011-11-20 | 934 |  | 200 | 200 | C | LND | XR80 | R | 11 | X | PI | LND | 1111 |  | 2011-08-17 |  |  |  |  |  |  |  |  |
|  | E | **Electrical** |  |  | 2011-05-17 | 2012-08-08 |  |  |  |  |  |  |  |  |  |  |  |  |  |  |  |  |  |  |  |  |  |  |  |  |  |  |  |  |  |  |  |  |  |  |  |  |  |  |  |  |  |  |  |  |  |  |  |  |  |  |  |  |  |  |  |  |  |  |  |  |  |  |  |
| XC911111 |  | CA11 OffgComprFilt - Install Earthing System_CIVIL |  | 5d | 2011-05-17 A | 2011-05-21 A | EE901111 (other project), XC201111 FF+3d, EE900010 (other project) | 100% |  |  |  | TB26 - V - Construct-Winter partly * | Grounding & Lightning [100 pcs]; Grounding & Lightning [1125 h] | 45,000 | 45,000 | 1125,00 |  |  |  |  |  |  |  | XC911111 | 1125 | 1125 | 11 |  | X | C | 1111 |  |  |  |  |  |  |  |  |  |  | MO11 |  |  |  |  | 934 |  | 200 | 200 | C | LND | XE91 | C | 11 | X | EA | LND | 1111 |  |  |  |  |  |  |  |  |  |  |
| XE401111 |  | CA11 OffgComprFi- Install Cable Trays |  | 20d | 2011-12-06 | 2012-01-25 | XR401111 SS+20d, XE405102 SS+20d, XN301111 |  | 24d | 0d |  | TB26 - V - Construct-Winter partly * | Cable trays/conduits [140 m]; Cable trays [420 h] | 16,800 |  | 420,00 |  |  |  |  |  |  |  | XE401111 | 420 | 0 | 11 |  | X | E | 1111 |  | E-15-01-07 |  |  |  |  |  |  | 2011-11-30 | 2011-09-20 | URMA |  |  | 2011-05-20 | 2011-08-20 | 934 |  | 200 | 200 | C | LND | XE40 | E | 11 | X | EL | LND | 1111 |  |  | UDF_G3 | m | 300 | 2011-07-02 | 2011-08-05 | x | to be checked |  |
| XE911112 |  | CA11 OffgComprFilt - Install Earthing System_E/I |  | 10d | 2011-12-06 | 2011-12-27 | XN301111, F-21302 FS+20d, F-21303, F-22303, F-22302 |  | 121d | 213.5d |  | TB26 - V - Construct-Winter partly * |  |  |  | 115 |  |  |  |  |  |  |  | XE911112 | 0 | 0 | 11 |  | X | E | 1111 |  | E-16-07-01 |  |  |  |  |  |  | 2012-05-10 | 2011-09-20 | URMA |  |  | 2011-05-10 | 2011-11-30 | 934 |  | 200 | 200 | C | LND | XE91 | E | 11 | X | EA | LND | 1111 |  |  | UDF_G3 |  |  |  |  |  |  |  |
| XE801111 |  | CA11 OffgComprFi - Install Heat Tracing |  | 30d | 2012-01-09 | 2012-03-09 | E3E1950 (other project), F-21302, P3E19S (other project), F-22302, F-22303, XW501111 FF+20d, F-21303, XR401111, XR601111 FF+10d |  | 81d | 4d |  | TB26 - V - Construct-Winter partly * | Electrical Heat Tracing [2000 m]; Electrical heat tracing [1000 h] | 40,000 |  | 1000,00 |  |  |  |  |  |  |  | XE801111 | 1000 | 0 | 11 |  | X | E | 1111 |  | E-16-04-01 |  |  |  |  |  | 005 | 2012-06-30 | 2011-09-15 | URMA |  |  | 2011-06-20 | 2012-03-20 | 934 |  | 200 | 200 | C | LND | XE80 | E | 11 | X | HT | LND | 1111 |  |  | UDF_G3 |  |  |  |  |  | to be installed later |  |
| XE341111 |  | CA11 OffgComprFi - Install Local Operation Panels |  | 10d | 2012-01-30 | 2012-02-20 | XE401111, F-21302, F-21303, F-22303, F-22302, XR401111 SS+20d |  | 68d | 83.5d |  | TB26 - V - Construct-Winter partly * | Field Panels [3 pcs]; Field panels [60 h] | 2,400 |  | 60,00 |  |  |  |  |  |  |  | XE341111 | 60 | 0 | 11 |  | X | E | 1111 |  | E-16-07-01 |  |  |  |  |  |  | 2012-05-10 | 2011-09-20 | URMA |  |  | 2011-05-10 | 2011-11-30 | 934 |  | 200 | 200 | C | LND | XE34 | E | 11 | X | EL | LND | 1111 |  |  | UDF_G3 |  |  |  |  |  | to be installed later |  |
| XE701111 |  | CA11 OffgComprFi - Install Lighting &Small Power |  | 40d | 2012-03-09 | 2012-04-24 | XE401111, EE76111010 (other project), XJ421111, XP341610 FS+50d, P3E09S (other project), EE761111 (other project) |  | 55d | 0d |  |  | Cable Pulling [400 m]; Lighting illuminates [40 pcs]; Lighting (iluminates) [400 h]; Cable pulling [200 h] | 24,000 |  | 600,00 |  |  |  |  |  |  |  | XE701111 | 600 | 0 | 11 |  | X | E | 1111 |  | E-16-03-01 |  |  |  |  |  |  | 2012-05-10 | 2011-08-15 | URMA |  |  | 2011-05-10 | 2012-01-31 | 934 |  | 200 | 200 | C | LND | XE70 | E | 11 | X | EL | LND | 1111 |  |  | UDF_G3 |  |  |  |  |  |  | x |
| XE921111 |  | CA11 OffgComprFi - Install Fire Detection System |  | 40d | 2012-04-25 | 2012-06-13 | XJ421111, XE701111 |  | 246.5d | 20d |  |  | Fire Detection System; Fire detection system |  |  | 0,00 |  |  |  |  |  |  |  | XE921111 | 0 | 0 | 11 |  | X | E | 1111 |  |  |  |  |  |  |  |  |  |  |  |  |  |  |  | 934 |  | 200 | 200 | C | UIO | XE92 | E | 11 | X | FGDS | LND | 1111 |  |  |  |  |  |  |  | x |  | x |
| XE961111 |  | CA11 OffgComprFi - Install Communication System |  | 60d | 2012-04-25 | 2012-07-06 | XE921111 FF, E3E1350 (other project), XE701111, P3E13S (other project), XJ421111 |  | 226.5d |  |  |  | Communication System |  |  | 0,00 |  |  |  |  |  |  |  | XE961111 | 0 | 0 | 11 |  | X | E | 1111 |  |  |  |  |  |  |  |  |  |  |  |  |  |  |  | 934 |  | 200 | 200 | C | LND | XE96 | E | 11 | X | CS | LND | 1111 |  |  |  |  |  |  |  | x |  | x |
| XE501111 |  | CA11 OffgComprFi - Cable Pulling Electric |  | 50d | 2012-05-29 | 2012-07-27 | P3E15BS (other project), EE561110 (other project), XE500C01, P3E15CS (other project), XE505201 SS+6d, P3E15AS (other project), XE401111, XE505401 SS+10d |  | -15.5d | 0d |  | TB26 - V - Construct-Winter partly * | Cable Pulling [4400 m]; Cable pulling [2200 h] | 88,000 |  | 2200,00 |  |  |  |  |  |  |  | XE501111 | 2200 | 0 | 11 |  | X | E | 1111 |  | E-16-01-01 |  |  |  |  |  |  | 2012-07-01 | 2011-10-01 | URMA |  |  | 2011-05-20 | 2012-02-10 | 934 |  | 200 | 200 | C | LND | XE50 | E | 11 | X | EL | LND | 1111 |  |  | UDF_G3 | m | 4500 | 2011-10-01 | 2011-12-14 |  |  |  |
| XE601111 |  | CA11 OffgComprFi - Cable Termination & Testing |  | 50d | 2012-06-09 | 2012-08-08 | XE501111 FF+10d, XE341111, F-21302, F-21303, F-22303, F-22302 |  | -15.5d | 15d |  |  | Cable connecting [100 pcs]; Cable connecting [250 h] | 10,000 |  | 250,00 |  |  |  |  |  |  |  | XE601111 | 250 | 0 | 11 |  | X | E | 1111 |  | E-16-02-01 |  |  |  |  |  |  | 2012-08-14 | 2011-12-10 | URMA |  |  | 2011-04-20 | 2011-11-30 | 934 |  | 200 | 200 | C | LND | XE60 | E | 11 | X | ET | LND | 1111 |  |  | UDF_G3 |  |  |  |  |  |  |  |

Notes:
- F-21302: Scope: Insulation: ET 80
- F-21303: Scope: Insulation: ET 80
- F-22302: Scope: Insulation: ET 80
- F-22303: Scope: Insulation: ET 80
- XB101111: Current Status: 17.01.2011 (Siegel): laut Vertrag ist das Enddatum / 30-Mar-11.
- XR201111: Current Status: 20110907 (O.Siegel): nach Rьcksprache mit M.Siegel, das Material fьr die / Prefab werden rausgegeben, sobald der Subkontractor die Prefab-Halle / fertiggestellt hat und genьgend SchweiЯer qualifiziert sind.

| ID | WBS | Activity | Type | Duration | Start | Finish | Predecessors | Total float | Free float | Calendar | Resources | Cost | TB26 Ressource Budget | UDF_CONTRACT START DATE | UDF_CONTRACT FINISH DATE | UDF_CONTRACT ITEM | UDF_CONTRACT INDICATOR | UDF_CONTRACT FINISH DATE REV1 | UDF_CONTRACT START DATE REV1 | UDF_SAVE ACT ID | UDF_BUDGETED LABOR UNIT | UDF_ACTUAL LABOR UNIT | Department | Constr. Area | PMT-Area | PMT-Schedule Org | PMT-Phase | PMT-Respons. | WBS Phase | WBS Discipline | WBS Type of Work | WBS Objects | Russia WBS Discipline (Russia) | Russia Construction Area | Russia WBS Phase | IMS | UPT | Russia WBS Objects | Subcontractor | Filter | TB26 Semantics | TB26 Material Res Values | UDF_ELECTRICAL START | UDF_ELECTRICAL FINISH | UDF_CHECK BASELINE | UDF_PENALIZED FINISH | UDF_BASELINE DEVELOPMENT | Type of Work | UDF_CHECK CRITICAL PATH |
| --- | --- | --- | --- | --- | --- | --- | --- | --- | --- | --- | --- | --- | --- | --- | --- | --- | --- | --- | --- | --- | --- | --- | --- | --- | --- | --- | --- | --- | --- | --- | --- | --- | --- | --- | --- | --- | --- | --- | --- | --- | --- | --- | --- | --- | --- | --- | --- | --- | --- |
|  | J | **Instrumentation** |  |  | 2011-12-06 | 2012-09-29 |  |  |  |  |  |  |  |  |  |  |  |  |  |  |  |  |  |  |  |  |  |  |  |  |  |  |  |  |  |  |  |  |  |  |  |  |  |  |  |  |  |  |  |
| XJ301111 |  | CA11 OffgComprFi - Install Field Instruments |  | 30d | 2011-12-06 | 2012-02-20 | P3J05S (other project), P3J04ES (other project), P3J13BS (other project), P3J13AS (other project), P3J04BS (other project), P3J12DS (other project), P3J12AS (other project), P3J13CS (other project), EJ361111 (other project), P3J14S (other project), P3J13S (other project), P3J04AS (other project), P3J14AS (other project), XR801111 FF, P3J14BS (other project), P3J12BS (other project), P3J07AS (other project), XR401111 SS+20d, F-21302, F-21303, F-22302, F-22303 | 51d | 0d | TB26 - V - Construct-Winter partly * | Field Instruments [29 pcs]; Install field instruments [160 h] | 6,380 | 160,00 | 2011-05-10 | 2012-02-20 | E-17-04-01 | UDF_G3 | 2012-07-20 | 2011-09-10 | XJ301111 | 160 | 0 | 934 | 11 | 200 | 200 | C | LND | X | J | XJ30 | 1111 | J | 11 | X | IN | LND | 1111 | URMA |  |  |  |  |  |  |  |  |  |  |
| XJ321111 |  | CA11 OffgComprFi - Install Junction Boxes |  | 30d | 2011-12-06 | 2012-02-20 | F-21302 FS+15d, F-21303 FS+15d, F-22303 FS+15d, F-22302 FS+15d, P3J06FS (other project), EJ321111 (other project), P3J06ES (other project) FS+14d, XR401111 SS+20d | 4d | 0d | TB26 - V - Construct-Winter partly * | Junction Boxes/Cabinets/Panels [15 pcs]; Install Junction Boxes/ Cabinets/ Panels [375 h] | 15,000 | 375,00 | 2011-05-10 | 2012-02-20 | E-17-04-01 | UDF_G3 | 2012-07-20 | 2011-09-10 | XJ321111 | 375 | 0 | 934 | 11 | 200 | 200 | C | LND | X | J | XJ32 | 1111 | J | 11 | X | IN | LND | 1111 | URMA |  |  |  |  |  |  |  |  |  |  |
| XJ421111 |  | CA11 OffgComprFi - Install Secondary Cable Trays |  | 20d | 2012-01-30 | 2012-03-07 | XJ321111 FF+10d, XE401111 FF, XR401111 SS+20d, F-21302, F-21303, F-22303, F-22302 | 4d | 0d | TB26 - V - Construct-Winter partly * | Secondary cable trays [130 m]; Install secondary cable trays [487.5 h] | 19,500 | 487,50 | 2011-05-20 | 2011-08-20 | E-15-01-07 |  | 2011-11-30 | 2011-09-20 | XJ421111 | 487,5 | 0 | 934 | 11 | 200 | 200 | C | LND | X | J | XJ42 | 1111 | J | 11 | X | IN | LND | 1111 | URMA | x | m | 200 | 2011-07-02 | 2011-08-05 | x |  |  |  |  |
| XJ701111 |  | CA11 OffgComprFi - Instrument Tubing |  | 30d | 2012-02-15 | 2012-03-22 | XJ301111 FF+20d, XR401111 | 53d | 48d |  |  |  |  | 2011-05-10 | 2012-02-20 | E-17-04-01 |  | 2012-07-20 | 2011-09-10 | XJ701111 | 0 | 0 | 934 | 11 | 200 | 200 | C | LND | X | J | XJ70 | 1111 | J | 11 | X | IN | LND | 1111 | URMA |  |  |  |  |  |  |  |  |  |  |
| XJ441111 |  | CA11 OffgComprFi - Install Conduits to Instrm |  | 30d | 2012-03-09 | 2012-04-12 | XJ321111, XJ421111, XE401111, XR401111 SS+2d, F-21302, F-21303, F-22302, F-22303 | 5d | 0d |  |  |  |  | 2011-05-10 | 2012-02-20 | E-17-04-01 |  | 2012-07-20 | 2011-09-10 | XJ441111 | 0 | 0 | 934 | 11 | 200 | 200 | C | LND | X | J | XJ44 | 1111 | J | 11 | X | IN | LND | 1111 | URMA |  |  |  |  |  |  |  |  |  |  |
| XJ541111 |  | CA11 OffgComprFi - Pulling Singlecore Cables |  | 30d | 2012-03-09 | 2012-04-17 | XJ441111 SS, XJ301111 FF+15d, EJ801111 (other project), XE500C01, XJ421111 | 51d | 46d | TB26 - V - Construct-Winter partly * | Singlecore cables [2400 m]; Pull singlecore cables [1800 h] | 72,000 | 1800,00 | 2011-05-10 | 2012-02-20 | E-17-04-01 |  | 2012-07-20 | 2011-09-10 | XJ541111 | 1800 | 0 | 934 | 11 | 200 | 200 | C | LND | X | J | XJ54 | 1111 | J | 11 | X | IN | LND | 1111 | URMA |  | m | 2255 | 2011-12-07 | 2012-02-21 |  |  |  |  |  |
| XJ391111 |  | CA11 OffgComprFi - Install Earthing Field Eqpt |  | 30d | 2012-04-13 | 2012-05-19 | XJ301111 FF+20d, XJ421111, XJ441111 | 5d | 0d |  |  |  |  | 2011-05-10 | 2012-02-20 | E-17-04-01 | UDF_G3 | 2012-07-20 | 2011-09-10 | XJ391111 | 0 | 0 | 934 | 11 | 200 | 200 | C | LND | X | J | XJ39 | 1111 | J | 11 | X | IN | LND | 1111 | URMA |  |  |  |  |  |  |  |  |  |  |
| XJ641111 |  | CA11 OffgComprFi - Termin Singlecore Cables |  | 30d | 2012-05-21 | 2012-06-25 | XJ541111 FF+10d, XJ301111, XJ321111, XJ391111, XJ701111 | 5d | 72.5d |  | Termination Field [705 mhr]; Termination field [705 h] | 70,500 | 705,00 | 2011-05-10 | 2012-02-20 | E-17-04-01 |  | 2012-07-20 | 2011-09-10 | XJ641111 | 705 | 0 | 934 | 11 | 200 | 200 | C | LND | X | J | XJ64 | 1111 | J | 11 | X | IN | LND | 1111 | URMA |  |  |  |  |  |  |  |  |  |  |
| XJ521111 |  | CA11 OffgComprFi - Pulling Multicore Cables |  | 30d | 2012-05-31 | 2012-07-06 | XJ321111 SS+20d, XJ525201 SS+10d, XE500C01, XE401111, XJ525401 SS+12d | 2.5d | 0d | TB26 - V - Construct-Winter partly * | Multicore cables [2200 m]; Pull multicore cables [1100 h] | 44,000 | 1100,00 | 2011-05-20 | 2012-03-10 | E-17-01-01 |  | 2012-06-16 | 2011-11-01 | XJ521111 | 1100 | 0 | 934 | 11 | 200 | 200 | C | LND | X | J | XJ52 | 1111 | J | 11 | X | IN | LND | 1111 | URMA |  | m | 1600 | 2011-10-29 | 2011-12-26 |  |  |  |  |  |
| XJ621111 |  | CA11 OffgComprFi - Termin Multicore Cables |  | 30d | 2012-06-13 | 2012-07-18 | XJ521111 FF+10d, XJ321111 | 2.5d | 33d |  | Termination Field [705 mhr]; Termination field [705 h] | 70,500 | 705,00 | 2011-05-20 | 2012-03-10 | E-17-01-01 |  | 2012-06-16 | 2011-11-01 | XJ621111 | 705 | 0 | 934 | 11 | 200 | 200 | C | LND | X | J | XJ62 | 1111 | J | 11 | X | IN | LND | 1111 | URMA |  |  |  |  |  |  |  |  |  |  |
| XJ801111 |  | CA11 OffgComprFi - Inspections/ Mech. Acceptance/ Loop Checks |  | 30d | 2012-08-25 | 2012-09-29 | X0300015, X030410030, XE601111, XJ391111 SF+10d, XJ701111 SS, X3J120, XJ641111 FF+10d, XJ621111 | -30.5d | 37d |  | Loop Checks [100 pcs]; Loop checks [500 h] | 20,000 | 500,00 | 2011-06-10 | 2012-04-30 | E-17-02-01 |  | 2012-08-18 | 2012-03-01 | XJ801111 | 500 | 0 | 934 | 11 | 200 | 200 | C | LND | X | J | XJ80 | 1111 | J | 11 | X | LT | LND | 1111 | URMA |  |  |  |  |  |  | 2012-08-18 |  |  |  |
|  | S | **Safety & Environment** |  |  |  |  |  |  |  |  |  |  |  |  |  |  |  |  |  |  |  |  |  |  |  |  |  |  |  |  |  |  |  |  |  |  |  |  |  |  |  |  |  |  |  |  |  |  |  |
|  | W | **Painting** |  |  | 2011-09-17 | 2011-11-21 |  |  |  |  |  |  |  |  |  |  |  |  |  |  |  |  |  |  |  |  |  |  |  |  |  |  |  |  |  |  |  |  |  |  |  |  |  |  |  |  |  |  |  |
| XW501111 |  | CA11 OffgComprFilt - Surf.Protection Piping |  | 55d | 2011-09-17 | 2011-11-21 | XR201111 SS | 151d | 66d |  | Piping painting [253 sqm]; Piping painting [633 h] | 564.66 | 633,00 |  |  |  |  |  |  | XW501111 | 633 | 0 | 934 | 11 | 200 | 200 | C | LND | X | W | XW50 | 1111 | W | 11 | X | PA | LND | 1111 |  |  |  |  |  |  |  |  |  |  |  |
|  | V | **Insulation** |  |  | 2012-03-01 | 2012-05-25 |  |  |  |  |  |  |  |  |  |  |  |  |  |  |  |  |  |  |  |  |  |  |  |  |  |  |  |  |  |  |  |  |  |  |  |  |  |  |  |  |  |  |  |
| XV301111 |  | CA11 OffgComprFilt - Insulation Equipment |  | 60d | 2012-03-01 | 2012-05-18 | F-22303 FF, XE801111 SS+20d, F-21303 FF, F-22302, F-21302, F-22302 FF, F-22303, XV300C00 SS, XR401111 FS+30d, F-21303 | 77d | 0d | TB26 - T - Construct-Winter-3 (Dec/Jan/Feb free) * | Equipment insulation [100 sqm]; Equipment insulation [1250 h] | 403.54 | 1250,00 |  | 2012-03-30 | E-13-03 |  |  |  | XV301111 | 1250 | 0 | 934 | 11 | 200 | 200 | C | LND | X | V | XV30 | 1111 | V | 11 | X | INS | LND | 1111 |  |  |  |  |  |  |  |  |  |  |  |
| XV501111 |  | CA11 OffgComprFilt - Insulation Piping |  | 60d | 2012-03-12 | 2012-05-25 | XR601111 SS+10d, XE801111 FF+20d, XV301111 FF+6d, XW501111 FF+20d | 77d | 144.5d | TB26 - T - Construct-Winter-3 (Dec/Jan/Feb free) * | Piping insulation [250 sqm]; Piping insulation [1875 h] | 1,608.26 | 1875,00 |  | 2012-04-30 | E-13-01 |  |  |  | XV501111 | 1875 | 0 | 934 | 11 | 200 | 200 | C | LND | X | V | XV50 | 1111 | V | 11 | X | INS | LND | 1111 |  |  |  |  |  |  |  |  |  |  |  |
|  | 20 | **CA11 - Propylen Recovery Section** |  |  |  |  |  |  |  |  |  |  |  |  |  |  |  |  |  |  |  |  |  |  |  |  |  |  |  |  |  |  |  |  |  |  |  |  |  |  |  |  |  |  |  |  |  |  |  |
|  | C | **Civil Work** |  |  |  |  |  |  |  |  |  |  |  |  |  |  |  |  |  |  |  |  |  |  |  |  |  |  |  |  |  |  |  |  |  |  |  |  |  |  |  |  |  |  |  |  |  |  |  |
|  | N | **Structural Steel** |  |  |  |  |  |  |  |  |  |  |  |  |  |  |  |  |  |  |  |  |  |  |  |  |  |  |  |  |  |  |  |  |  |  |  |  |  |  |  |  |  |  |  |  |  |  |  |
|  | H | **HVAC** |  |  |  |  |  |  |  |  |  |  |  |  |  |  |  |  |  |  |  |  |  |  |  |  |  |  |  |  |  |  |  |  |  |  |  |  |  |  |  |  |  |  |  |  |  |  |  |
|  | U | **Package Units** |  |  |  |  |  |  |  |  |  |  |  |  |  |  |  |  |  |  |  |  |  |  |  |  |  |  |  |  |  |  |  |  |  |  |  |  |  |  |  |  |  |  |  |  |  |  |  |
|  | B | **Mechanical - Stationary Equipment** |  |  |  |  |  |  |  |  |  |  |  |  |  |  |  |  |  |  |  |  |  |  |  |  |  |  |  |  |  |  |  |  |  |  |  |  |  |  |  |  |  |  |  |  |  |  |  |
|  | M | **Mechanical - Rotating Equipment** |  |  |  |  |  |  |  |  |  |  |  |  |  |  |  |  |  |  |  |  |  |  |  |  |  |  |  |  |  |  |  |  |  |  |  |  |  |  |  |  |  |  |  |  |  |  |  |
|  | R | **Piping** |  |  |  |  |  |  |  |  |  |  |  |  |  |  |  |  |  |  |  |  |  |  |  |  |  |  |  |  |  |  |  |  |  |  |  |  |  |  |  |  |  |  |  |  |  |  |  |
|  | E | **Electrical** |  |  |  |  |  |  |  |  |  |  |  |  |  |  |  |  |  |  |  |  |  |  |  |  |  |  |  |  |  |  |  |  |  |  |  |  |  |  |  |  |  |  |  |  |  |  |  |
|  | J | **Instrumentation** |  |  |  |  |  |  |  |  |  |  |  |  |  |  |  |  |  |  |  |  |  |  |  |  |  |  |  |  |  |  |  |  |  |  |  |  |  |  |  |  |  |  |  |  |  |  |  |
|  | S | **Safety & Environment** |  |  |  |  |  |  |  |  |  |  |  |  |  |  |  |  |  |  |  |  |  |  |  |  |  |  |  |  |  |  |  |  |  |  |  |  |  |  |  |  |  |  |  |  |  |  |  |
|  | W | **Painting** |  |  |  |  |  |  |  |  |  |  |  |  |  |  |  |  |  |  |  |  |  |  |  |  |  |  |  |  |  |  |  |  |  |  |  |  |  |  |  |  |  |  |  |  |  |  |  |
|  | V | **Insulation** |  |  |  |  |  |  |  |  |  |  |  |  |  |  |  |  |  |  |  |  |  |  |  |  |  |  |  |  |  |  |  |  |  |  |  |  |  |  |  |  |  |  |  |  |  |  |  |
|  | 30 | **CA11 - Flare Knockout Drum Section** |  |  |  |  |  |  |  |  |  |  |  |  |  |  |  |  |  |  |  |  |  |  |  |  |  |  |  |  |  |  |  |  |  |  |  |  |  |  |  |  |  |  |  |  |  |  |  |
|  | 12 | **CA12 - Polymerisation Line 1** |  |  | 2008-09-24 | 2012-11-30 |  |  |  |  |  |  |  |  |  |  |  |  |  |  |  |  |  |  |  |  |  |  |  |  |  |  |  |  |  |  |  |  |  |  |  |  |  |  |  |  |  |  |  |
|  | 00 | **CA12 - General** |  |  | 2008-09-24 | 2012-11-30 |  |  |  |  |  |  |  |  |  |  |  |  |  |  |  |  |  |  |  |  |  |  |  |  |  |  |  |  |  |  |  |  |  |  |  |  |  |  |  |  |  |  |  |
|  | 0B | **General Activities** |  |  | 2012-09-12 | 2012-11-30 |  |  |  |  |  |  |  |  |  |  |  |  |  |  |  |  |  |  |  |  |  |  |  |  |  |  |  |  |  |  |  |  |  |  |  |  |  |  |  |  |  |  |  |
| X0101210 |  | CA12 General - Construction Completion | milestone | 0d | 2012-09-12 | 2012-09-12 | XC801201, XN601201, CY-21202, E-21206, MI-21202, V-21224, HO-21204, XE801204, XN601205, P-21103 A/B, XR401221, XC191200, XN801201, HO-21201, C-21801, HO-21203, HO-21208, PK-21211, XR401201, XN601221, HO-21101, XE801221, XJ391221, XH00122205, XE911242, XC191205, XC301200, XE701200, XC20120107, XN201201u, XE801201, XJ301201, XE501204, XC501221, XH00122105, V-21103, MI-21104 A/B, P-21102 A/B, XJ641221, MI-21108 A/B, XJ441222, P-21203, XE501233, XC801704, MI-21801, R-21201, V-21223, HO-21209, XE501201, XJ641201, XJ521204, XN801221, AG-21101, XE701221, XE601221, XN601222, XJ641222, XR401230, P-21201A/B, XE911235, K-21201A/B, XE501232, XE911234, XJ641233, AG-21201, XC191305, XN401201, AG-21201-MI01, E-21203, HO-21210, XE911205, XJ542101, XJ391201, V-21101, V-21108, P-21106, MI-21107 A/B, XE701222, XE911225, XJ441230, K-21801, XJ441233, XC601200, XC18120108, V-21201, HO-21202, XE601201, XE911206, P-21107, XN801222, XE601232, XJ641232, XJ541232, XR401233, XE601233, V-21221, HO-21206, HE-21108, MI-21101, XJ541221, XE501222, XE601230, XJ641230, XR401232, V-21222, HO-21205, XJ701201, XN601204, XR401204, V-21106, P-21101A/B, P-21108, MI-21106 A/B, XE911224, XJ701221, XC501222, XR401222, XE601222, XJ701222, XE501230, XJ541230, XJ541233, XH601200, XC111196035, XE501221, XJ391222, XJ391230, XJ391232, XJ391233 | -73.5d | 38d | TB26 - 2 - Manuf and Delivy |  |  |  |  |  |  |  |  |  | X0101210 | 0 | 0 | 934 | 12 | 200 | 200 | C | LND | X | 0B | X010 | 1200 | 0 | 12 | X | MC | LND | 1200 |  |  |  |  |  |  |  |  | XC301200 | XNK |  |
| X0101200 |  | CA12 General - Mechanical Completion | milestone | 0d | 2012-11-30 | 2012-11-30 | XJ801201, XV501201 FF, XE911224, XE601230, XC20120107, XC18120108, XV301201, XE911235, XV501232, XC801201, XE911205, XV501204 FF, XE701221, XJ801221, XV501222, XV501230, XC601200, XE601222, XV301222, XV301233, XE911234, XH00122110, XV301232, XE911242, XV501233, XC801704, P3R01S (other project), XE701200, XV301221, XV501221, XE701222, XV301230, XH601200, X0101210, XE911206, XE601221, XE911225, XJ801222, XE601232, XJ801232 FS+20d, XJ801233 FS+20d, P3J03S4 (other project), XN401201, XE601201, XH00122210, XJ801230, XE601233 | -97.5d | 29d | TB26 - 2 - Manuf and Delivy |  |  |  |  |  |  |  |  |  | X0101200 | 0 | 0 | 934 | 12 | 200 | 200 | C | LND | X | 0B | X010 | 1200 | 0 | 12 | X | MC | LND | 1200 |  |  |  |  |  |  |  |  |  | XNK | SK1206 |

Notes:
- XW501111: P3 Activity Log Info: Clarification Surface Protection during Prefab

| ID | WBS | Activity | Type | Duration | Start | Finish | Predecessors | Complete | Remaining | Planned start | Planned finish | Total float | Free float | Constraint | Calendar | Resources | Cost | Actual cost | UDF_SAVE ACT ID | UDF_BUDGETED LABOR UNIT | UDF_ACTUAL LABOR UNIT | Department | Constr. Area | PMT-Area | PMT-Schedule Org | PMT-Phase | PMT-Respons. | WBS Phase | WBS Discipline | WBS Type of Work | WBS Objects | Russia WBS Discipline (Russia) | Russia Construction Area | Russia WBS Phase | IMS | UPT | Russia WBS Objects | Subcontractor | TB26 Ressource Budget | Inquiry/Order No | suspend date | resume date | UDF_CONTRACT INDICATOR | UDF_BASELINE DEVELOPMENT | UDF_SELECT UPDATE PROGRESS | UDF_CHECK BASELINE | UDF_CHECK RESOURCE DATES | Check ResLoading | Filter | UDF_Concrete | UDF_CHECK CRITICAL PATH | Zeigen/n. Zeigen | UDF_CONTRACT START DATE | UDF_CONTRACT FINISH DATE | UDF_CONTRACT ITEM | UDF_CONTRACT FINISH DATE REV1 | UDF_CONTRACT START DATE REV1 | geplanter Start | geplantes Ende | 4 week lookahead | Comments | Civil item |
| --- | --- | --- | --- | --- | --- | --- | --- | --- | --- | --- | --- | --- | --- | --- | --- | --- | --- | --- | --- | --- | --- | --- | --- | --- | --- | --- | --- | --- | --- | --- | --- | --- | --- | --- | --- | --- | --- | --- | --- | --- | --- | --- | --- | --- | --- | --- | --- | --- | --- | --- | --- | --- | --- | --- | --- | --- | --- | --- | --- | --- | --- | --- |
|  | C | **Civil Work** |  |  | 2008-09-24 | 2012-06-19 |  |  |  |  |  |  |  |  |  |  |  |  |  |  |  |  |  |  |  |  |  |  |  |  |  |  |  |  |  |  |  |  |  |  |  |  |  |  |  |  |  |  |  |  |  |  |  |  |  |  |  |  |  |  |  |  |
| XC111200 |  | CA12 General - Excavation&Surface Prep U/I/O |  | 294d | 2008-09-24 A | 2009-09-30 A | F2760 (other project) | 100% |  |  |  |  |  |  |  |  |  |  | XC111200 | 0 | 0 | 934 | 12 | 200 | 200 | C | UIO | X | C | XC11 | 1200 | C | 12 | X | EQ | LND | 1200 | MO11 |  |  |  |  |  |  |  |  |  |  |  |  |  |  |  |  |  |  |  |  |  |  |  |  |
| XC11120005 |  | CA12 General - Excavation outs.Reactor Structure |  | 15d | 2010-03-29 A | 2010-04-14 A | XC111200 | 100% |  |  |  |  |  |  |  | Excavation [4000 cbm]; Excavation [2000 h] | 160,000 | 160,000 | XC11120005 | 2000 | 2000 | 934 | 12 | 200 | 200 | C | MO02 | X | C | XC11 | 1200 | C | 10 | X | P | LND | 1010 | MO11 | 2000,00 | 999 |  |  |  |  |  |  |  |  |  |  |  |  |  |  |  |  |  |  |  |  |  |  |
| XC11120010 |  | CA12 General - SubBase (Gravel/Geogrid) for Concrete |  | 16d | 2010-04-15 A | 2010-05-05 A | XC11120005 | 100% |  | 2010-04-15 | 2010-05-04 |  |  |  |  | Sub Base for Concrete/Paving&Roads (Gravel) [10000 cbm]; Subbase for Concrete [10000 h] | 1,000,000 | 350,000 | XC11120010 | 10000 | 10000 | 934 | 12 | 200 | 200 | C | MO02 | X | C | XC11 | 1200 | C | 10 | X | P | LND | 1010 | MO11 | 10000,00 | 999 |  |  |  |  |  |  |  |  |  |  |  |  |  |  |  |  |  |  |  |  |  |  |
| XC151200 |  | CA12 General - Piling outs.Reactor Structure |  | 27d | 2010-04-28 A | 2010-05-29 A | XC151201 SS, F2910, EC151232 (other project) FF+10d, EC151233 (other project) FF+10d, EC151204 (other project) FS+5d, EC151221 (other project) FF+10d, XC11120005, XC111200, XC11120010, EC151205 (other project) FS+10d, EC151222 (other project) FF+10d | 100% |  |  |  |  |  |  |  | Piles driven [367 pcs]; Piles driven [2753 h] | 110,100 | 110,100 | XC151200 | 2753 | 2753 | 934 | 12 | 200 | 200 | C | MO02 | X | C | XC15 | 1200 | C | 12 | X | P | LND | 1200 | MO11 | 2753,00 |  |  |  |  |  |  |  |  |  |  |  |  |  |  |  |  |  |  |  |  |  |  |  |
| XC191205 |  | CA12 General - Backfill |  | 103d | 2011-07-04 A | 2011-10-15 |  |  | 13d | 2011-07-04 | 2011-10-31 | -43d | 31d |  | TB26 - T - Construct-Winter-3 (Dec/Jan/Feb free) * | Backfill & Compaction [8000 cbm]; Backfill & Compaction [12000 h] | 720,000 | 712,800 | XC191205 | 12000 | 0 | 934 | 12 | 200 | 200 | C | CiC | X | C | XC19 | 1200 | C | 12 | X | UG | LND | 1200 | MO11 | 24000,00 |  | 2010-11-01 | 2010-11-30 | UDF_G4 | XC301200 | 27.8. | x | actual finish | X |  |  |  |  |  |  |  |  |  |  |  |  |  |  |
| XC191200 |  | CA12 General - Backfill |  | 30d | 2011-10-21 | 2012-03-05 | XC911232 FF+20d, XC911201 FF+20d, XC911204 FF+20d, IMS-C-000070 FF, XC911233 FF+20d, XC301200 FF+10d, XC911222 FF+20d, XC20120105, XC911221 FF, XC911230 FF+20d |  |  |  |  | 53d | 0d |  | TB26 - T - Construct-Winter-3 (Dec/Jan/Feb free) * | Backfill & Compaction [8000 cbm]; Backfill & Compaction [12000 h] | 720,000 |  | XC191200 | 12000 | 12000 | 934 | 12 | 200 | 200 | C | CiC | X | C | XC19 | 1200 | C | 12 | X | UG | LND | 1200 | MO11 | 12000,00 |  | 2010-11-01 | 2010-11-30 |  |  |  |  |  |  | 1 |  |  |  |  |  |  |  |  |  |  |  |  |  |
| XC301200 |  | CA12 General - UG Installation (incl. Precast Manholes) |  | 60d | 2011-12-07 | 2012-02-21 | XC20120410 FF+10d, XC310C00, XC20120110 SS+30d, XC300C00, P3R02AS1 (other project), P3R02AS1 (other project) FF, ER441200 (other project), XC300C10, P3S08S (other project) FF+30d, XC300C00 SS, P3R02S1 (other project), XC201232 FF+20d, P3R01S (other project) FF, P3R02S1 (other project) FF, XC401221 FF+20d, XC401222 FF+10d, P3C02D4 (other project) FS+20d, P3R02BS (other project), XC191205 |  |  |  |  | -86d | 0d |  |  | Cast Iron U/G Piping [575 m]; Concrete Manholes [17 pcs]; Floor Drains / Catch Basins [2 pcs]; Fire water hydrants/monitors [3 pcs]; FRP U/G Piping [305 m]; Cast iron U/G piping [11500 h]; concrete manholes [4812 h]; floor drains / catch basins [62 h]; fire water hydrants/ monitors [187 h]; FRP U/G piping [3812 h] | 361,250.38 |  | XC301200 | 20373 | 0 | 934 | 12 | 200 | 200 | C | CiC | X | C | XC30 | 1200 | C | 12 | X | UG | LND | 1200 |  | 40750,00 |  |  |  |  | XC301200 |  |  |  | UG |  | 1 | XC301200 | C5 |  |  |  |  |  |  |  |  |  |  |
| XC301210 |  | CA12 General - UG Installation (incl. Precast Manholes) |  | 40d | 2012-03-01 | 2012-04-18 |  |  |  |  |  | 10.5d | 0d | start on or after 2012-03-01 |  | Cast Iron U/G Piping [575 m]; Concrete Manholes [18 pcs]; Floor Drains / Catch Basins [3 pcs]; Fire water hydrants/monitors [3 pcs]; FRP U/G Piping [305 m]; Cast iron U/G piping [11500 h]; concrete manholes [4813 h]; floor drains / catch basins [63 h]; fire water hydrants/ monitors [188 h]; FRP U/G piping [3813 h] | 373,250.38 |  | XC301200 | 20377 | 0 | 934 | 12 | 200 | 200 | C | CiC | X | C | XC30 | 1200 | C | 12 | X | UG | LND | 1200 |  | 40750,00 |  |  |  |  | XC301200 |  |  |  | UG |  | 1 | XC301200 | C5 |  |  |  |  |  |  |  |  |  |  |
| XH601200 |  | CA12 General - Snow Melting System |  | 15d | 2012-03-17 | 2012-04-03 | XH000000 FF, XC191205 FF+20d, XC191200 SS+20d, XC301200, IMS-P-000100 FF, XC191205 SS+20d, XC191200 FF+20d, EC601200 (other project) FS+20d |  |  |  |  | 53d | 0d |  |  |  |  |  | XH601200 | 17685 | 0 | 934 | 12 | 200 | 200 | C | CiC | X | H | XH00 | 1200 | H | 12 | X | OB | LND | 1200 | ARMO | 200 |  |  |  |  | XC301200 |  | x |  |  |  | 1 |  |  |  |  |  |  |  |  |  |  |  |  |
| XC111196015 |  | CA12 General - Backfill |  | 30d | 2012-03-23 | 2012-04-30 | XC301210 FF+10d |  |  |  |  | 10.5d | 0d |  | TB26 - T - Construct-Winter-3 (Dec/Jan/Feb free) * | Backfill & Compaction [8000 cbm]; Backfill & Compaction [12000 h] | 720,000 |  | XC191205 | 12000 | 0 | 934 | 12 | 200 | 200 | C | CiC | X | C | XC19 | 1200 | C | 12 | X | UG | LND | 1200 | MO11 | 24000,00 |  | 2010-11-01 | 2010-11-30 |  | XC301200 |  | x |  | X | 1 |  |  |  |  |  |  |  |  |  |  |  |  |  |
| XC601200 |  | CA12 General - Paving inside / outside |  | 20d | 2012-04-04 | 2012-04-26 | IMS-P-000100 FF, XH000000 FF, XC191200 FF+20d, XC191205 SS+20d, EC601200 (other project) FS+20d, XC191205 FF+20d, XH601200, XC191200 SS+20d |  |  |  |  | 53d | 115.5d |  |  | Concrete paved areas & concrete Roads [2350 sqm]; Open ditches; Gravel [600 sqm]; Concrete paved areas & concrete roads [8812 h]; open ditches; Gravel [30 h] | 18,616.61 |  | XC601200 | 8842 | 0 | 934 | 12 | 200 | 200 | C | CiC | X | C | XC60 | 1200 | C | 12 | X | OB | LND | 1200 | MO11 | 17685,00 |  |  |  |  | XC301200 |  | x |  |  |  | 1 |  |  |  |  |  |  |  |  |  |  |  |  |
| XH601310 |  | CA12 General - Snow Melting System |  | 10d | 2012-05-14 | 2012-05-25 | XC111196015 FF+20d, XC301210, XC111196015 SS+20d |  |  |  |  | 10.5d | 0d |  |  |  |  |  | XH601200 | 17685 | 0 | 934 | 12 | 200 | 200 | C | CiC | X | H | XH00 | 1200 | H | 12 | X | OB | LND | 1200 | ARMO | 200 |  |  |  |  | XC301200 |  | x |  |  |  | 1 |  |  |  |  |  |  |  |  |  |  |  |  |
| XC111196035 |  | CA12 General - Paving inside / outside |  | 20d | 2012-05-25 | 2012-06-19 | XC111196015 SS+20d, XC111196015 FF+20d, XH601310 |  |  |  |  | 10.5d | 73d |  |  | Concrete paved areas & concrete Roads [2350 sqm]; Open ditches; Gravel [600 sqm]; Concrete paved areas & concrete roads [8813 h]; open ditches; Gravel [30 h] | 18,616.61 |  | XC601200 | 8843 | 0 | 934 | 12 | 200 | 200 | C | CiC | X | C | XC60 | 1200 | C | 12 | X | OB | LND | 1200 | MO11 | 17685,00 |  |  |  |  | XC301200 |  | x |  |  |  | 1 |  |  |  |  |  |  |  |  |  |  |  |  |
|  | E | **Electrical** |  |  | 2012-05-11 | 2012-09-22 |  |  |  |  |  |  |  |  |  |  |  |  |  |  |  |  |  |  |  |  |  |  |  |  |  |  |  |  |  |  |  |  |  |  |  |  |  |  |  |  |  |  |  |  |  |  |  |  |  |  |  |  |  |  |  |  |
| XE701200 |  | CA12 General - Install Lighting & Small Power |  | 65d | 2012-05-11 | 2012-07-26 | XJ421204 FF, XE401232, EE761200 (other project), XN601201, XE401230, XP341610 FS+50d, XE401201, XE401221, P3E09S (other project), EE76120010 (other project), XJ421201, XE401204, XJ421232, XJ421233, XJ421221 FS-10d, XE401222, XE401233, XJ421230, EE76510110 (other project) |  |  |  |  | -22d | 0d |  |  | Cable Pulling [1200 m]; Lighting illuminates [170 pcs]; Lighting (iluminates) [1700 h]; Cable pulling [600 h] | 92,000 |  | XE701200 | 2300 | 0 | 934 | 12 | 200 | 200 | C | LND | X | E | XE70 | 1200 | E | 12 | X | EL | LND | 1200 | URMA | 2300,00 |  |  |  |  |  |  |  |  |  | x |  |  |  | 2011-05-10 | 2012-01-31 | E-16-03-01 | 2012-05-10 | 2011-08-15 |  |  |  |  |  |
| XE921200 |  | CA12 General - Install Fire Detection System |  | 50d | 2012-07-27 | 2012-09-22 | XE701200, XN601201 |  |  |  |  | 159.5d | 0d |  |  | Fire Detection System; Fire detection system |  |  | XE921200 | 0 | 0 | 934 | 12 | 200 | 200 | C | UIO | X | E | XE92 | 1200 | E | 12 | X | FGDS | LND | 1200 |  | 0,00 |  |  |  |  |  |  | x |  |  | x |  |  |  |  |  |  |  |  | 2012-02-13 | 2012-07-09 |  |  |  |
| XE961200 |  | CA12 General - Install Communication System |  | 50d | 2012-07-27 | 2012-09-22 | XN601201, XE701200, XE921200 SS |  |  |  |  | 159.5d |  |  |  | Communication System |  |  | XE961200 | 0 | 0 | 934 | 12 | 200 | 200 | C | UIO | X | E | XE96 | 1200 | E | 12 | X | CS | LND | 1200 |  | 0,00 |  |  |  |  |  |  | x |  |  | x |  |  |  |  |  |  |  |  | 2012-02-13 | 2012-07-09 |  |  |  |
|  | 01 | **CA12 - Reactor Structure** |  |  | 2010-03-29 | 2012-11-30 |  |  |  |  |  |  |  |  |  |  |  |  |  |  |  |  |  |  |  |  |  |  |  |  |  |  |  |  |  |  |  |  |  |  |  |  |  |  |  |  |  |  |  |  |  |  |  |  |  |  |  |  |  |  |  |  |
|  | C | **Civil Work** |  |  | 2010-03-29 | 2012-06-08 |  |  |  |  |  |  |  |  |  |  |  |  |  |  |  |  |  |  |  |  |  |  |  |  |  |  |  |  |  |  |  |  |  |  |  |  |  |  |  |  |  |  |  |  |  |  |  |  |  |  |  |  |  |  |  |  |
| XC111201 |  | CA12 ReactorStruc - Excavation |  | 15d | 2010-03-29 A | 2010-04-14 A | XC111200 | 100% |  |  |  |  |  |  |  | Excavation [13300 cbm]; Excavation [6650 h] | 532,000 | 532,000 | XC111201 | 6650 | 6650 | 934 | 12 | 200 | 200 | C | MO02 | X | C | XC11 | 1201 | C | 10 | X | P | LND | 1010 | MO11 | 6650,00 | 999 |  |  |  |  |  |  |  |  |  |  |  | C8 |  |  |  |  |  |  |  |  |  |  |
| XC11120110 |  | CA12 ReactorStruc - SubBase (Gravel/Geogrid) for Concrete |  | 16d | 2010-04-15 A | 2010-05-04 A | XC111201 | 100% |  |  |  |  |  |  |  | Sub Base for Concrete/Paving&Roads (Gravel) [1000 cbm]; Subbase for Concrete [1000 h] | 100,000 | 100,000 | XC11120110 | 1000 | 1000 | 934 | 12 | 200 | 200 | C | MO02 | X | C | XC11 | 1201 | C | 10 | X | P | LND | 1010 | MO11 | 1000,00 | 999 |  |  |  |  |  |  |  |  |  |  |  | C8 |  |  |  |  |  |  |  |  |  |  |
| XC151201 |  | CA12 ReactorStruc - Piling |  | 42d | 2010-04-28 A | 2010-06-16 A | XC111201, F2910, P3C01D1 (other project), EC151201 (other project) FS+16d, XC11120110 FS-4d, P3C02D1 (other project) | 100% |  |  |  |  |  |  |  | Piles driven [234 pcs]; Piles driven [1755 h] | 2,084.23 |  | XC151201 | 1755 | 1755 | 934 | 12 | 200 | 200 | C | MO02 | X | C | XC15 | 1201 | C | 12 | X | P | LND | 1201 | MO11 | 1755,00 |  |  |  |  |  |  |  |  |  |  |  |  | C8 |  |  |  |  |  |  |  |  |  |  |
| XC20120105 |  | CA12 ReactorStruc - Concrete Works Base Plate |  | 19d | 2010-06-21 A | 2010-07-12 A | EC28120105 (other project) FS+5d, EC45120105 (other project) FF, XC151201 | 100% |  |  |  |  |  |  | TB26 - V - Construct-Winter partly * | Concrete works [1000 cbm]; Concrete works [30000 h] | 1,200,000 | 1,200,000 | XC20120105 | 30000 | 30000 | 934 | 12 | 200 | 200 | C | MO03 | X | C | XC20 | 1201 | C | 12 | X | mai | LND | 1201 | MO11 | 30000,00 |  |  |  |  |  |  |  |  |  |  |  |  | C8 |  |  |  |  |  |  |  |  |  |  |
| XC20120108 |  | CA12 ReactorStruc - Concrete Works Piperack Foundations |  | 124d | 2010-08-30 A | 2011-01-29 A | XC20120105 FS+36d | 100% |  |  |  |  |  |  |  | Concrete works [50 cbm]; Concrete works [1500 h] | 41,980.2 |  | XC20120108 | 1500 | 1500 | 934 | 12 | 200 | 200 | C | MO03 | X | C | XC20 | 1201 | C | 12 | X | mai | LND | 1201 | MO11 | 1500,00 |  |  |  |  |  |  |  |  |  |  |  |  | C8 |  |  |  |  |  |  |  |  |  |  |
| XC20120110 |  | CA12 ReactorStruc SK1201 - Concrete Works Structure+6m |  | 70d | 2010-08-31 A | 2010-11-30 A | EC28120110 (other project) FS+5d, P3C02D2 (other project) FS+25d, EC45120105 (other project), EC44120005 (other project) FF, EC28120112 (other project) FF+20d, XC20120105 | 100% |  |  |  |  |  |  | TB26 - V - Construct-Winter partly * | Concrete works [550 cbm]; Concrete works [16500 h] | 660,000 | 660,000 | XC20120110 | 16500 | 16500 | 934 | 12 | 200 | 200 | C | MO04 | X | C | XC40 | 1201 | C | 12 | X | OB | LND | 1201 | MO11 | 16500,00 |  |  |  |  |  |  |  |  |  |  |  |  | C8 |  |  |  |  |  |  |  |  |  |  |
| XC20120115 |  | CA12 ReactorStruc SK1201- Precast Concrete Elements |  | 37d | 2010-11-22 A | 2011-02-16 A | EC28120112 (other project) FS+5d, P3C02D2 (other project) | 100% |  |  |  |  |  |  | TB26 - V - Construct-Winter partly * |  |  |  | XC20120115 | 0 | 0 | 934 | 12 | 200 | 200 | C | MO04 | X | C | XC40 | 1201 | C | 12 | X | pre | LND | 1204 | MO11 |  |  |  |  |  |  |  |  |  |  |  |  |  |  |  |  |  |  |  |  |  | x |  |  |
| XC20120109 |  | CA12 ReactorStruc - Concrete Works Structure+6m finished | milestone | 0d | 2010-11-30 A | 2010-11-30 A | XC20120110 FF | 100% |  |  |  |  |  |  | TB26 - V - Construct-Winter partly * |  |  |  | XC20120109 | 0 | 0 | 934 | 12 | 200 | 200 | C | MO04 | X | C | XC40 | 1201 | C | 12 | X | mai | LND | 1201 | MO11 |  |  |  |  |  |  |  |  |  |  |  |  |  |  |  |  |  |  |  |  |  |  |  |  |
| XC20120120 |  | CA12 ReactorStruc SK1201 - Erection Precast Elements (SK1201) |  | 16d | 2011-01-31 A | 2011-03-05 A | XC20120115 FS-5d, XC20120110 FS+6d, XC20120108 | 100% |  | 2011-01-31 | 2011-03-04 |  |  |  | TB26 - V - Construct-Winter partly * | Precast Concrete Works [70 cbm]; Precast concrete works [175 h] | 7,000 | 7,000 | XC20120120 | 175 | 175 | 934 | 12 | 200 | 200 | C | MO04 | X | C | XC40 | 1201 | C | 12 | X | OB | LND | 1204 | MO11 | 175,00 |  |  |  |  |  |  |  |  |  |  |  |  |  |  |  |  |  |  |  |  | x | finished | Comp |
| XC20120106 |  | CA12 ReactorStruc - Concrete Works Eqpt Fdt |  | 10d | 2011-05-03 A | 2011-05-14 A | XC20120109 | 100% |  |  |  |  |  |  | TB26 - V - Construct-Winter partly * |  |  |  | XC20120106 | 0 | 0 | 934 | 12 | 200 | 200 | C | MO03 | X | C | XC20 | 1201 | C | 12 | X | ML | LND | 1201 | MO11 | 1100 |  |  |  |  |  |  | x |  |  |  |  |  | EQ |  |  |  |  |  |  |  |  |  |  |
| XC20130106 |  | CA12 ReactorStruc - Concrete Works Eqpt Fdt/Pedestels +6m |  | 10d | 2011-05-03 A | 2011-05-14 A | XC20130109 | 100% |  |  |  |  |  |  | TB26 - V - Construct-Winter partly * |  |  |  | XC20130106 | 0 | 0 | 934 | 13 | 200 | 200 | C | MO03 | X | C | XC20 | 1301 | C | 12 | X | ML | LND | 1201 | MO11 | 1100 |  |  |  |  |  |  |  |  |  |  |  |  | EQ |  |  |  |  |  |  |  |  |  |  |
| XC18120108 |  | CA12 ReactorStruc - Concrete Works Piperack Foundations (Coating/Grouting) |  | 10d | 2012-02-22 | 2012-03-05 | XC21120100 SS, XN201201u, XC301200, XC191205 |  |  |  |  | 97d | 159.5d |  |  | Concrete works [60 cbm]; Concrete works [1800 h] |  |  | XC18120108 | 300 | 0 | 934 | 12 | 200 | 200 | C | MO03 | X | C | XC20 | 1201 | C | 12 | X | mai | LND | 1201 | MO11 | 300,00 |  |  |  |  |  |  |  |  |  | 1 |  |  | C8 |  |  |  |  |  |  |  |  |  |  |
| XC21120100 |  | CA12 ReactorStruc - Concrete Works Base Plate (Coating/Grouting) |  | 20d | 2012-02-22 | 2012-03-23 | XC20120105, XR401201, XC191205, XC301200 |  |  |  |  | 80d | 0d |  | TB26 - V - Construct-Winter partly * | Concrete works [330 cbm]; Concrete works [9900 h] | 396,000 |  | XC21120100 | 9900 | 0 | 934 | 12 | 200 | 200 | C | MO03 | X | C | XC20 | 1201 | C | 12 | X | mai | LND | 1201 | MO11 | 9900,00 |  |  |  |  |  |  |  |  |  | 1 |  |  | C8 |  |  |  |  |  |  |  |  |  |  |
| XC20120107 |  | CA12 ReactorStruc - Concrete Works Base Plate finished | milestone | 0d | 2012-03-23 | 2012-03-23 | XC20120105 FF, XC21120100 FF |  |  |  |  | 80d | 142.5d |  | TB26 - V - Construct-Winter partly * |  |  |  | XC20120107 | 0 | 0 | 934 | 12 | 200 | 200 | C | MO03 | X | C | XC20 | 1201 | C | 12 | X | mai | LND | 1201 | MO11 |  |  |  |  |  |  |  |  |  |  |  |  |  |  |  |  |  |  |  |  |  |  |  |  |
| XC801201 |  | CA12 ReactorStruc SK1201/SK1200 - Fire Proofing |  | 45d | 2012-04-16 | 2012-06-08 | XN201201u FF+20d, XN201201l, IMS-C-000130 FF, IMS-C-000130 SS, IMS-C-000135 |  |  |  |  | 18d | 80.5d | start on or after 2012-04-16 | TB26 - T - Construct-Winter-3 (Dec/Jan/Feb free) * | Fire proofing [150 sqm]; Fire proofing [1125 h] | 23,362.57 |  | XC801201 | 937,5 | 0 | 934 | 12 | 200 | 200 | C | CiC | X | C | XC80 | 1201 | C | 12 | X | FP | LND | 1201 | KRILAK | 937,50 |  |  |  |  |  |  |  |  |  |  | 1 |  |  |  |  |  |  |  |  |  |  |  |  |

Notes:
- XC111200: P3 Activity Log Info: incl. Dewatering/Drainage
- XC151200: P3 Activity Log Info: 645 driven piles expected
- XC301200: P3 Activity Log Info: Clarification Prefab / Catch Basins/pulling pits
- XC301210: P3 Activity Log Info: Clarification Prefab / Catch Basins/pulling pits
- XE921200: Scope: CA12 Polymerization Line 1 / FDS - 49 external sensors / GDS - 29 external sensors / DS + SAME
- XE961200: Scope: CA12 Polymerization Line 1 / FDS - 49 external sensors / GDS - 29 external sensors / DS + SAME
- XC151201: P3 Activity Log Info: 94 bored piles d=120cm, 2/d/machine
- XC20120115: Current Status: 05.02.2011 (O.Siegel): Termin wird gehalten (MO11 am 04.02.2011) / 12.01.2011 (Oxana): laut Aussage von Mostostoy (am 11.01.2011) sind ca. 40% / der Arbeiten abgeschlossen. Enddatum auf den 17.01.2011 verschoben.
- XC20120120: Current Status: 09.03.2011 (O.Siegel): die Pedestels werden frьhestens zum 28.03.2011 / fertiggestelt und kцnnen an die CSK ьbergeben werden (Info aus dem weekly / meeting). / 19.02.2011 (O.Siegel): es besteht die Gefahrt, dass der Termin nicht gehalten / wird. bis 18-Feb-11 hat MO11 erst 7 Sockel betoniert. Goran hat MO11 aufgefort, / einen Team zu moiliesieren, die Vorbereitungsarbeiten durchfьhren mьssen. / 05.02.2011 (O.Siegel): Termin wird gehalten (MO11 am 04.02.2011) / 13.01.2011 (Oxana): zum 01.01.2011 wurden keine Arbeiten durchgefьhrt / (Angaben aus CPMR). Startdatum auf den 10.01.2011 verschoben und die Dauer von / 15 auf 10 Tage verkьrzt. Endtermin wird gehalten (Angaben von Mostostroy).
- XC20120106: Current Status: 14.05.2011 (O.Siegel): die / Pipesupports werden spдter fertiggestellt werden
- XC801201: Scope: SK1200: / No. of beams/ columns: 14 (fire Resistance R120) / Length 24,77m; Weight: 925,46 kg; Surface Area 24,90 sqm / SK1201: / No. of beams/ columns: 16 (fire Resistance R120) / Length 54,03m; Weight: 10285,68 kg; Surface Area 122,7 / sqm / Current Status: 20110906 (O.Siegel): die / Prioritдten fьr Fire Proofing: 17 - 3101 - 1101. die restlichen CA werden / in 2012 gefertigt

| ID | WBS | Activity | Type | Duration | Start | Finish | Predecessors | Complete | Remaining | Planned start | Planned finish | Total float | Free float | Constraint | Calendar | Resources | Cost | Actual cost | TB26 Ressource Budget | UDF_SAVE ACT ID | UDF_CHECK BASELINE | UDF_BUDGETED LABOR UNIT | UDF_ACTUAL LABOR UNIT | Department | Type of Work | Constr. Area | PMT-Area | PMT-Schedule Org | PMT-Phase | PMT-Respons. | Zeigen/n. Zeigen | WBS Phase | WBS Discipline | WBS Type of Work | WBS Objects | Russia WBS Discipline (Russia) | Russia Construction Area | Russia WBS Phase | IMS | UPT | Russia WBS Objects | Inquiry/Order No | UDF_CONTRACT START DATE | UDF_CONTRACT FINISH DATE | UDF_CONTRACT ITEM | TB26 Semantics | 4 week lookahead | Subcontractor | UDF_CONTRACT INDICATOR | UDF_SELECT UPDATE PROGRESS | UDF_CHECK RESOURCE DATES | UDF_COMMENTS | UDF_Weight (ton) | WEIGHT | UDF_LEVEL | UDF_PO No | UDF_TAG No | UDF_Object No | UDF_DELIVERY DATE PO | UDF_DELIVERY DATE DISPATCH PLANNED | UDF_DELIVERY DATE TO SITE PLANNED | UDF_DELIVERY DATE SITE NEED DATE | UDF_SHIPMENT No | UDF_SUPPLIER | Filter | UDF_DELIVERY DATE DISPATCH ACTUAL | Check ResLoading | UDF_Vendor Representatives | Comments | Drawing Indicator |
| --- | --- | --- | --- | --- | --- | --- | --- | --- | --- | --- | --- | --- | --- | --- | --- | --- | --- | --- | --- | --- | --- | --- | --- | --- | --- | --- | --- | --- | --- | --- | --- | --- | --- | --- | --- | --- | --- | --- | --- | --- | --- | --- | --- | --- | --- | --- | --- | --- | --- | --- | --- | --- | --- | --- | --- | --- | --- | --- | --- | --- | --- | --- | --- | --- | --- | --- | --- | --- | --- | --- |
|  | N | **Structural Steel** |  |  | 2011-02-07 | 2011-11-07 |  |  |  |  |  |  |  |  |  |  |  |  |  |  |  |  |  |  |  |  |  |  |  |  |  |  |  |  |  |  |  |  |  |  |  |  |  |  |  |  |  |  |  |  |  |  |  |  |  |  |  |  |  |  |  |  |  |  |  |  |  |  |  |  |
| XN701201 |  | CA12 ReactorStruc SK1201/00- KMD Assy Drawings (lower part - first erection parts) | milestone | 0d | 2011-02-07 A | 2011-02-07 A |  | 100% |  |  |  |  |  | finish on 2011-02-06 | TB26 - V - Construct-Winter partly * |  |  |  | 22t | XN701201 | x | 0 | 0 | 934 | XNK | 12 | 200 | 200 | C | LND | KMD | X | N | XN05 | 1201 | N | 12 | X | SS | LND | 1201 |  |  |  |  |  |  |  |  |  |  |  |  |  |  |  |  |  |  |  |  |  |  |  |  |  |  |  |  |  |
| XN711201 |  | CA12 ReactorStruc SK1201 - Steel Deliveries (lower part - first erection parts) | milestone | 0d | 2011-02-18 A | 2011-02-18 A |  | 100% |  |  |  |  |  | finish on 2011-02-18 | TB26 - 3 - Construction Normal 7days * CA17 |  |  |  | 22t | XN711201 |  | 0 | 0 | 934 | XNK | 12 | 200 | 200 | C | LND | SD | X | N | XN06 | 1201 | N | 12 | X | SS | LND | 1201 |  |  |  |  |  |  |  |  |  |  |  |  |  |  |  |  |  |  |  |  |  |  |  |  |  |  |  |  |  |
| XN721201 |  | CA12 ReactorStruc SK1201 - KMD Assy Drawings (lower part) | milestone | 0d | 2011-02-28 A | 2011-02-28 A |  | 100% |  |  |  |  |  | finish on 2011-02-25 | TB26 - V - Construct-Winter partly * |  |  |  | 22t | XN721201 | x | 0 | 0 | 934 | XNK | 12 | 200 | 200 | C | LND | KMD | X | N | XN05 | 1201 | N | 12 | X | SS | LND | 1201 |  |  |  |  |  |  |  |  |  |  |  |  |  |  |  |  |  |  |  |  |  |  |  |  |  |  |  |  |  |
| XN701200 |  | CA12 ReactorStruc SK1200- KMD Assy Drawings | milestone | 0d | 2011-02-28 A | 2011-02-28 A |  | 100% |  |  |  |  |  | finish on 2011-02-28 | TB26 - V - Construct-Winter partly * |  |  |  | 22t | XN701200 | x | 0 | 0 | 934 | XNK | 12 | 200 | 200 | C | LND | KMD | X | N | XN05 | 1201 | N | 12 | X | PR | LND | 1200 | 999 |  |  |  |  |  |  |  |  |  |  |  |  |  |  |  |  |  |  |  |  |  |  |  |  |  |  |  |  |
| XN731201 |  | CA12 ReactorStruc SK1201 - Steel Deliveries (lower part) | milestone | 0d | 2011-03-06 A | 2011-03-06 A |  | 100% |  |  |  |  |  | finish on 2011-03-06 | TB26 - 3 - Construction Normal 7days * CA17 |  |  |  | 22t | XN731201 |  | 0 | 0 | 934 | XNK | 12 | 200 | 200 | C | LND | SD | X | N | XN06 | 1201 | N | 12 | X | SS | LND | 1201 |  |  |  |  |  |  |  |  |  |  |  |  |  |  |  |  |  |  |  |  |  |  |  |  |  |  |  |  |  |
| XN741201 |  | CA12 ReactorStruc SK1201- KMD Assy Drawings (upper part) | milestone | 0d | 2011-03-11 A | 2011-03-11 A |  | 100% |  |  |  |  |  | finish on 2011-03-11 | TB26 - V - Construct-Winter partly * |  |  |  | 22t | XN741201 | x | 0 | 0 | 934 | XNK | 12 | 200 | 200 | C | LND | KMD | X | N | XN05 | 1201 | N | 12 | X | SS | LND | 1201 |  |  |  |  |  |  |  |  |  |  |  |  |  |  |  |  |  |  |  |  |  |  |  |  |  |  |  |  |  |
| XN201201l |  | CA12 ReactorStruc SK1201/00 - Erection/Preassembly Primary Steel +30m (lower part) |  | 61d | 2011-03-23 A | 2011-06-06 A | XN100C00, XN711201, XC20120120 FF+15d, P3N02DN (other project), XN721201 FF-7d, XN731201 FF-17d, XN701201, XB30120110, P3N012D (other project) FS+10d | 100% |  | 2011-03-23 | 2011-06-04 |  |  |  | TB26 - V - Construct-Winter partly * | Piperacks, Main structures [14195 h]; Piperacks, Main Structures [334 t] | 20,251.01 |  | 14195,00 | XN201201l |  | 14195 | 14195 | 934 | XNK | 12 | 200 | 200 | C | LND |  | X | N | XN20 | 1201 | N | 12 | X | SS | LND | 1201 |  | 2010-12-27 | 2011-03-30 | E-04-02 | t | x | ChSK |  |  |  |  |  |  |  |  |  |  |  |  |  |  |  |  |  |  |  |  |  |  |
| XN711200 |  | CA12 ReactorStruc SK1200 - Steel Deliveries | milestone | 0d | 2011-03-27 A | 2011-03-27 A |  | 100% |  |  |  |  |  | finish on or after 2011-03-15 | TB26 - 3 - Construction Normal 7days * CA17 |  |  |  | 22t | XN711200 |  | 0 | 0 | 934 | XNK | 12 | 200 | 200 | C | LND | SD | X | N | XN06 | 1201 | N | 12 | X | PR | LND | 1200 | 999 |  |  |  |  |  |  |  |  |  |  |  |  |  |  |  |  |  |  |  |  |  |  |  |  |  |  |  |  |
| XN751201 |  | CA12 ReactorStruc SK1201- Steel Deliveries (upper part) | milestone | 0d | 2011-03-27 A | 2011-03-27 A |  | 100% |  |  |  |  |  | finish on 2011-03-25 | TB26 - 3 - Construction Normal 7days * CA17 |  |  |  | 22t | XN751201 |  | 0 | 0 | 934 | XNK | 12 | 200 | 200 | C | LND | SD | X | N | XN06 | 1201 | N | 12 | X | SS | LND | 1201 |  |  |  |  |  |  |  |  |  |  |  |  |  |  |  |  |  |  |  |  |  |  |  |  |  |  |  |  |  |
| XN601201 |  | CA12 ReactorStruc SK1201/00 - Install Gratings |  | 124d | 2011-05-07 A | 2011-09-30 | PN691201 (other project), XN401201 SS |  | 30d |  |  | -94d | 0d |  |  | Grating [2500 sqm]; Grating [9375 h] | 116,406.36 |  | 9375,00 | XN601201 |  | 9375 | 1016 | 934 | XNK | 12 | 200 | 200 | C | LND |  | X | N | XN60 | 1201 | N | 12 | X | SS | LND | 1201 |  | 2010-12-27 | 2011-03-30 | E-04-02 |  | x | ChSK | UDF_G4 | 27.8. | actual finish |  |  |  |  |  |  |  |  |  |  |  |  |  |  |  |  |  |  |  |
| XN201201u |  | CA12 ReactorStruc SK1201/00 - Erection/Preassembly Primary Steel +30m (upper part) |  | 105d | 2011-05-31 A | 2011-09-30 | XN741201, P3N02DN (other project), XN751201 FS+10d, XN100C00, XC20120120 FF+20d, XN201201l FS-5d, XN701200, XN711200, P3N012D (other project) FS+10d, AG-21201-MI01 SS+5d, XB30120110 | 100% | 30d |  |  | -70d | 0d |  | TB26 - V - Construct-Winter partly * | Piperacks, Main structures [15810 h]; Piperacks, Main Structures [372 t] | 20,251.01 |  | 15810,00 | XN201201u |  | 15810 | 3697 | 934 | XNK | 12 | 200 | 200 | C | LND |  | X | N | XN20 | 1201 | N | 12 | X | SS | LND | 1201 |  | 2010-12-27 | 2011-03-30 | E-04-02 | t |  | ChSK | UDF_G4 | 27.8. | actual finish |  |  |  |  |  |  |  |  |  |  |  |  |  |  |  |  |  |  |  |
| XN251201 |  | CA12 ReactorStruc SK1201(Pipe Rack) - Installation fireproof castables |  | 19d | 2011-07-06 A | 2011-07-27 A | XN201201l FS+21d | 100% |  |  |  |  |  |  | TB26 - V - Construct-Winter partly * |  |  |  | 702 | XN251201 |  | 0 | 0 | 934 | XNK | 12 | 200 | 200 | C | LND |  | X | N | XN20 | 1201 | N | 12 | X | SS | LND | 1201 |  | 2010-12-27 | 2011-03-30 | E-04-02 | t |  | MO11 | UDF_G4 |  |  | action by MO11 |  |  |  |  |  |  |  |  |  |  |  |  |  |  |  |  |  |  |
| XN401201 |  | CA12 ReactorStruc SK1201/00 - Install Railing, Ladders |  | 59d | 2011-07-25 A | 2011-09-30 | XN201201l SS+10d |  | 30d |  |  | 223d | 285.5d |  |  | Ladders & platforms [33 t]; Ladders & platforms [3300 h] | 1,345.14 |  | 3300,00 | XN401201 |  | 3300 | 0 | 934 | XNK | 12 | 200 | 200 | C | LND |  | X | N | XN40 | 1201 | N | 12 | X | SS | LND | 1201 |  | 2010-12-27 | 2011-03-30 | E-04-02 |  | x | ChSK | UDF_G4 | 27.8. | x |  |  |  |  |  |  |  |  |  |  |  |  |  |  |  |  |  |  |  |
| XN801201 |  | CA12 ReactorStruc SK1201/00 - Install Cladding |  | 30d | 2011-10-01 | 2011-11-07 | EN801201 (other project), XN201201l, XN201201u |  |  |  |  | 11d | 0d |  | TB26 - V - Construct-Winter partly * | Cladding [590 sqm]; Cladding [2950 h] | 665.18 |  | 2950,00 | XN801201 |  | 2950 | 0 | 934 | XNK | 12 | 200 | 200 | C | LND |  | X | N | XN80 | 1201 | N | 12 | X | SS | LND | 1201 |  |  |  |  |  |  | ChSK |  |  |  |  |  |  |  |  |  |  |  |  |  |  |  |  |  |  |  |  |  |  |
|  | H | **HVAC** |  |  |  |  |  |  |  |  |  |  |  |  |  |  |  |  |  |  |  |  |  |  |  |  |  |  |  |  |  |  |  |  |  |  |  |  |  |  |  |  |  |  |  |  |  |  |  |  |  |  |  |  |  |  |  |  |  |  |  |  |  |  |  |  |  |  |  |  |
|  | U | **Package Units** |  |  |  |  |  |  |  |  |  |  |  |  |  |  |  |  |  |  |  |  |  |  |  |  |  |  |  |  |  |  |  |  |  |  |  |  |  |  |  |  |  |  |  |  |  |  |  |  |  |  |  |  |  |  |  |  |  |  |  |  |  |  |  |  |  |  |  |  |
|  | B | **Mechanical - Stationary Equipment** |  |  | 2010-12-06 | 2012-05-29 |  |  |  |  |  |  |  |  |  |  |  |  |  |  |  |  |  |  |  |  |  |  |  |  |  |  |  |  |  |  |  |  |  |  |  |  |  |  |  |  |  |  |  |  |  |  |  |  |  |  |  |  |  |  |  |  |  |  |  |  |  |  |  |  |
| XB30120105 |  | CA12 ReactorStruc - Crane Mobilisation Reactor |  | 6d | 2010-12-06 A | 2010-12-13 A | XB30130110 SF-1d, XB30120110 SF-1d | 100% |  | 2010-12-06 | 2010-12-11 |  |  |  |  |  |  |  |  | XB30120105 |  | 0 | 0 | 934 | XBB | 12 | 200 | 200 | C | LND | C8 | X | B | XB30 | 1201 | B | 12 | X | HL | LND | 1201 |  | 2010-12-10 | 2010-12-20 | E-08-01-01 |  |  | VNZM |  |  |  |  |  |  |  |  |  |  |  |  |  |  |  |  |  |  |  |  |  |  |
| R-21201 |  | REACTOR |  | 4d | 2010-12-10 A | 2010-12-14 A | XB30120110 SS | 100% |  |  |  |  |  |  |  | Static Equipment > 10 tons [255.5 t]; Static equipment >10t [19068.5 h] | 766,500 | 766,500 | 19162,50 | R-21201 |  | 19068,5 | 19068,5 |  |  | 12 |  |  |  |  | EQ | X | B |  | 1201 |  |  |  |  |  |  |  |  |  |  |  |  | VNZM |  |  |  |  | 256 | 256000 | concrete +6.90 | 2 DC 844 / 9 | R-21201 | SK1201 | 2010-05-04 | 2010-06-16 | 2010-08-15 | 2010-09-30 | 1085 | Coek |  |  |  |  |  |  |
| V-21201 |  | REACTOR OVERHEAD SEPARATOR |  | 1d | 2010-12-10 A | 2010-12-14 A | XB30120110 SS | 100% |  | 2011-09-19 | 2011-09-19 |  |  | start on or after 2011-09-19 |  | Static Equipment > 10 tons [49.3 t]; Static equipment >10t [3675 h] | 147,900 | 147,000 | 3675,00 | V-21201 |  | 3675 | 0 |  |  | 12 |  |  |  |  | EQ | X | B |  | 1201 |  |  |  |  |  |  |  |  |  |  |  |  | VNZM |  |  |  |  | 49 | 49000 | concrete +9.00 | 2 DC 8500/ 3 | V-21201 | SK1201 | 2010-05-04 | 2010-05-04 | 2010-09-01 | 2010-09-01 | 4000 | Wonil | 1 | 2010-07-05 | X |  |  |  |
| XN001201 |  | CA12 ReactorStruc - Ready for Install Reactor | milestone | 0d | 2010-12-13 A | 2010-12-13 A | XC20120110 FF+5d | 100% |  |  |  |  |  |  |  |  |  |  |  | XN001201 |  | 0 | 0 | 934 | XNK | 12 | 200 | 200 | C | LND |  | X | B | X000 | 1201 | 0 | 12 | X | EQ | LND | 1201 |  |  |  |  |  |  | VNZM |  |  |  |  |  |  |  |  |  |  |  |  |  |  |  |  |  |  |  |  |  |  |
| XB30120110 |  | CA12 ReactorStruc - Heavy Lift Reactor w. Agitators, depends on agency approval |  | 4d | 2010-12-14 A | 2010-12-17 A | XC20120109, XN001301, P3B110 (other project), P3ALL1S1 (other project) FS+6d, ER291200 (other project), XN001201 | 100% |  |  |  |  |  |  |  |  |  |  | 291 | XB30120110 |  | 0 | 0 | 934 | XBB | 12 | 200 | 200 | C | LND | C8 | X | B | XB30 | 1201 | B | 12 | X | HL | LND | 1201 |  |  |  |  |  |  | VNZM |  |  |  |  |  |  |  |  |  |  |  |  |  |  |  |  |  |  |  |  |  |  |
| AG-21201-MI01 |  | REACTOR AGITATOR GEAR UNIT |  | 15d | 2011-05-25 A | 2011-06-10 A | XN601201 SS+10d, P3M11S1 (other project), XC20120106, XM001201 SS, XM001201 FF | 100% |  |  |  |  |  |  |  | Rotating Equipment (w/ lube oil unit) [31.1 t]; Rotating equipment (w/ lube oil unit) [3052.78 h] | 124,400 | 116,625 | 3500,00 | AG-21201-MI01 |  | 3052,78 | 3052,78 |  |  | 12 |  |  |  |  | EQ | X | M |  | 1201 |  |  |  |  |  |  |  |  |  |  |  |  | VNZM |  |  |  |  | 31,1 | 31100 | concrete +6.90 | 2 KB 429/ 2 | AG-21201-MI01 | SK1201 | 2010-12-01 | 2011-01-30 | 2011-01-28 | 2010-12-22 | 1001 | Lufkin |  |  |  | 029 |  |  |
| XB001201 |  | CA12 ReactorStruc - Install Static Eqpt | level of effort | 170d | 2011-05-26 A | 2012-01-19 |  |  | 118d | 2011-05-26 | 2011-12-12 | -72d | 0d |  |  |  |  |  | 113 | XB001201 |  | 0 | 0 | 934 | XBB | 12 | 200 | 200 | C | LND |  | X | B | XB00 | 1201 | B | 12 | X | EQ | LND | 1201 |  | 2011-02-10 | 2011-04-30 | E-08-01-07 |  |  | VNZM | UDF_G4 | 27.8. |  |  |  |  |  |  |  | SK1201 |  |  |  |  |  |  |  |  |  |  | E-08-01-07 | UDF_G2 |
| E-21206 |  | REACTOR OVERHEAD CONDENSER |  | 1d | 2011-06-24 A | 2011-06-24 A | XB001201 SS, XN201201u SS+20d, XB001201 FF, AG-21201-MI01, ER291200 (other project), XN201201l, P3A04S1 (other project) | 100% |  |  |  |  |  |  |  | Static Equipment > 10 tons [64.7 t]; Static equipment >10t [4852 h] | 194,100 | 194,100 | 4875,00 | E-21206 |  | 4852 | 4852 |  |  | 12 |  |  |  |  | EQ | X | B |  | 1201 |  |  |  |  |  |  |  |  |  |  |  |  | VNZM |  |  |  |  | 64,7 | 64700 | structure +19.80 | 2 DC 9110 | E-21206 | SK1201 | 2010-10-02 | 2010-11-23 | 2010-12-15 | 2011-02-10 | 1000 | W. Tosto Linde Impianti |  |  |  |  |  |  |
| HO-22203 |  | TROLLEY ELECTRICAL |  | 5d | 2011-09-26 | 2011-09-30 | XN201301l, P3A12S5 (other project), ER291300 (other project) |  |  |  |  | -34d | 50d |  |  | Static Equipment < 10 tons [0.3 t]; Static equipment < 10t [30 h] | 1,200 |  | 30,00 | HO-22203 | x | 30 | 0 |  |  | 13 |  |  |  |  | EQ | X | B |  | 1301 |  |  |  |  |  |  |  |  |  |  |  |  | VNZM |  |  |  |  | 0,3 | 6700 | structure +11.5 |  | HO-22203 | SK1301 |  | 2011-01-09 |  | 2011-02-01 |  |  |  |  |  |  |  |  |
| HO-22204 |  | MANUAL TROLLEY HAND GEARED |  | 4d | 2011-09-26 | 2011-09-29 | ER291300 (other project), XN201301l, P3A12S5 (other project) |  |  |  |  | -33d | 51d |  |  | Static Equipment < 10 tons [0.3 t]; Static equipment < 10t [30 h] | 1,200 |  | 30,00 | HO-22204 | x | 30 | 0 |  |  | 13 |  |  |  |  | EQ | X | B |  | 1301 |  |  |  |  |  |  |  |  |  |  |  |  | VNZM |  |  |  |  | 0,3 | 6700 | structure +3.9 |  | HO-22204 | SK1301 |  | 2011-01-09 |  | 2011-02-01 |  |  |  |  |  |  |  |  |
| HO-22205 |  | OVERHEAD TRAVELLING CRANE (for P-22201A) |  | 5d | 2011-09-26 | 2011-09-30 | ER291300 (other project), P3A12S5 (other project), XN201301l |  |  |  |  | -34d | 50d |  |  | Static Equipment < 10 tons [0.3 t]; Static equipment < 10t [30 h] | 1,200 |  | 30,00 | HO-22205 | x | 30 | 0 |  |  | 13 |  |  |  |  | EQ | X | B |  | 1301 |  |  |  |  |  |  |  |  |  |  |  |  | VNZM |  |  |  |  | 0,3 | 6700 | structure +3.9 |  | HO-22205 | SK1301 |  | 2011-01-09 |  | 2011-02-01 |  |  |  |  |  |  |  |  |
| HO-22206 |  | OVERHEAD TRAVELLING CRANE (for P-22201B) |  | 4d | 2011-09-26 | 2011-09-29 | XN201301l, P3A12S5 (other project), ER291300 (other project) |  |  |  |  | -33d | 51d |  |  | Static Equipment < 10 tons [0.3 t]; Static equipment < 10t [30 h] | 1,200 |  | 30,00 | HO-22206 | x | 30 | 0 |  |  | 13 |  |  |  |  | EQ | X | B |  | 1301 |  |  |  |  |  |  |  |  |  |  |  |  | VNZM |  |  |  |  | 0,3 | 6700 | structure +3.9 |  | HO-22206 | SK1301 |  | 2011-01-09 |  | 2011-02-01 |  |  |  |  |  |  |  |  |
| HO-22208 |  | OVERHEAD TRAVELLING CRANE (Manual Trolley hand geared) |  | 4d | 2011-09-26 | 2011-09-29 | ER291300 (other project), P3A12S5 (other project) |  |  |  |  | -33d | 51d |  |  | Static Equipment < 10 tons [0.3 t]; Static equipment < 10t [30 h] | 1,200 |  | 30,00 | HO-22208 | x | 30 | 0 |  |  | 13 |  |  |  |  | EQ | X | B |  | 1301 |  |  |  |  |  |  |  |  |  |  |  |  | VNZM |  |  |  |  | 0,3 | 6700 |  |  | HO-22208 | SK1301 |  | 2011-01-09 |  | 2011-02-01 |  |  |  |  |  |  |  |  |
| HO-22209 |  | OVERHEAD TRAVELLING CRANE |  | 5d | 2011-09-26 | 2011-09-30 | ER291300 (other project), P3A12S5 (other project) |  |  |  |  | -34d | 50d |  |  | Static Equipment < 10 tons [0.3 t]; Static equipment < 10t [30 h] | 1,200 |  | 30,00 | HO-22209 |  | 30 | 0 |  |  | 13 |  |  |  |  | EQ | X | B |  | 1301 |  |  |  |  |  |  |  |  |  |  |  |  | VNZM |  |  |  |  | 0,3 | 6700 |  |  | HO-22209 | SK1301 |  | 2011-01-09 |  | 2011-02-01 |  |  |  |  |  |  |  |  |
| HO-22202 |  | TROLLEY ELECTRICAL |  | 4d | 2011-10-01 | 2011-10-05 | P3A12S5 (other project), XN201301u, XN201301l, ER291300 (other project) |  |  |  |  | -38d | 46d |  |  | Static Equipment < 10 tons [0.3 t]; Static equipment < 10t [30 h] | 1,200 |  | 30,00 | HO-22202 | x | 30 | 0 |  |  | 13 |  |  |  |  | EQ | X | B |  | 1301 |  |  |  |  |  |  |  |  |  |  |  |  | VNZM |  |  |  |  | 0,3 | 6700 | structure +17.5 |  | HO-22202 | SK1301 |  | 2011-01-09 |  | 2011-02-01 |  |  |  |  |  |  |  |  |
| MI-22202 |  | REACTOR FINES EDUCTOR |  | 10d | 2011-10-01 | 2011-10-12 | AG-22201-MI01, XN201301u, P3A07S2 (other project), XN601301, ER291300 (other project) |  |  |  |  | -44d | 40d |  |  | Static Equipment < 10 tons [0.25 t]; Static equipment < 10t [25 h] | 1,000 |  | 25,00 | MI-22202 | x | 25 | 0 |  |  | 13 |  |  |  |  | EQ | X | B |  | 1301 |  |  |  |  |  |  |  |  |  |  |  |  | VNZM |  |  |  |  | 0,25 | 1900 | concrete +20.00 |  | MI-22202 | SK1301 |  |  |  |  |  | BERTIN |  |  |  |  |  |  |
| V-22222 |  | INSTRUMENT AIR VESSEL |  | 10d | 2011-10-01 | 2011-10-12 | XN201301u, XN601301 |  |  |  |  | -44d | 40d |  |  | Static Equipment < 10 tons [1.2 t]; Static equipment < 10t [120 h] | 4,800 |  | 120,00 | V-22222 | x | 120 | 0 |  |  | 13 |  |  |  |  | EQ | X | B |  | 1301 |  |  |  |  |  |  |  |  |  |  |  |  | VNZM |  |  |  |  | 1 | 1200 | structure | 2 DD 8530 | V-22222 | SK1201 | 2010-10-02 | 2010-11-30 | 2011-02-10 | 2010-12-23 |  | Linde E. India |  |  |  |  |  |  |
| C-21801 |  | TEAL STRIPPING COLUMN |  | 10d | 2011-10-10 | 2011-10-20 | P3A01S3 (other project), ER291200 (other project), XB001201 SS, XB001201 FF, XN201201l |  |  |  |  | -21d | 17d |  |  | Static Equipment < 10 tons [1.75 t]; Static equipment < 10t [175 h] | 7,000 |  | 175,00 | C-21801 |  | 175 | 0 |  |  | 12 |  |  |  |  | EQ | X | B |  | 1201 |  |  |  |  |  |  |  |  |  |  |  |  | VNZM |  |  |  |  | 1,75 | 1750 | structure +1.95 | 2 DD 8530 | C-21801 | SK1201 | 2010-10-02 | 2010-11-30 | 2011-02-10 | 2011-03-10 |  | Linde E. India |  |  |  |  | Intall Heat Tracing ET60 |  |
| V-22223 |  | INSTRUMENT AIR VESSEL |  | 10d | 2011-10-10 | 2011-10-20 | XN601301, XC201300, XN201301u, ER291300 (other project), P3A02CS1 (other project) |  |  |  |  | -71d | 0d |  |  | Static Equipment < 10 tons [1.35 t]; Static equipment < 10t [135 h] | 5,400 |  | 135,00 | V-22223 |  | 135 | 0 |  |  | 13 |  |  |  |  | EQ | X | B |  | 1301 |  |  |  |  |  |  |  |  |  |  |  |  | VNZM |  |  |  |  | 1,35 | 1350 | concrete +9.00 | 2 DD 8530 | V-22223 | SK1201 | 2010-10-02 | 2010-11-30 | 2011-02-10 | 2010-12-23 |  | Linde E. India |  |  |  |  |  |  |
| HO-21201 |  | OVERHEAD TRAVELLING CRANE (over Gear-Unit) |  | 5d | 2011-10-17 | 2011-10-21 | XN201201l, XN201201u, XB001201 SS, P3A12S4 (other project) FS+20d, XB001201 FF |  |  |  |  | -2d | 72d |  |  | Static Equipment < 10 tons [6.7 t]; Static equipment < 10t [670 h] | 26,800 |  | 670,00 | HO-21201 |  | 670 | 0 |  |  | 12 |  |  |  |  | EQ | X | B |  | 1201 |  |  |  |  |  |  |  |  |  |  |  |  | VNZM |  |  |  |  | 6,7 | 6700 | structure +15.365 |  | HO-21201 | SK1201 |  | 2011-01-09 |  | 2011-02-01 |  |  |  |  |  |  |  |  |
| HO-21202 |  | TROLLEY ELECTRICAL |  | 3.75d | 2011-10-17 | 2011-10-20 | XB001201 SS, P3A12S4 (other project) FS+20d, XN201201l, XN201201u, XB001201 FF |  |  |  |  | -0.75d | 73.25d |  |  | Static Equipment < 10 tons [0.3 t]; Static equipment < 10t [30 h] | 1,200 |  | 30,00 | HO-21202 |  | 30 | 0 |  |  | 12 |  |  |  |  | EQ | X | B |  | 1201 |  |  |  |  |  |  |  |  |  |  |  |  | VNZM |  |  |  |  | 0,3 | 6700 | structure +17.5 |  | HO-21202 | SK1201 |  | 2011-01-09 |  | 2011-02-01 |  |  |  |  |  |  |  |  |
| HO-21203 |  | TROLLEY ELECTRICAL |  | 3.75d | 2011-10-17 | 2011-10-20 | XN201201l, XB001201 SS, P3A12S4 (other project) FS+20d, XB001201 FF |  |  |  |  | -0.75d | 73.25d |  |  | Static Equipment < 10 tons [0.3 t]; Static equipment < 10t [30 h] | 1,200 |  | 30,00 | HO-21203 |  | 30 | 0 |  |  | 12 |  |  |  |  | EQ | X | B |  | 1201 |  |  |  |  |  |  |  |  |  |  |  |  | VNZM |  |  |  | ??? for Gear-Unit installation??? | 0,3 | 6700 | structure +11.5 |  | HO-21203 | SK1201 |  | 2011-01-09 |  | 2011-02-01 |  |  |  |  |  |  |  |  |
| HO-21204 |  | MANUAL TROLLEY HAND GEARED |  | 3.75d | 2011-10-17 | 2011-10-20 | XB001201 SS, P3A12S4 (other project) FS+20d, XN201201l, XB001201 FF |  |  |  |  | -0.75d | 73.25d |  |  | Static Equipment < 10 tons [0.3 t]; Static equipment < 10t [30 h] | 1,200 |  | 30,00 | HO-21204 |  | 30 | 0 |  |  | 12 |  |  |  |  | EQ | X | B |  | 1201 |  |  |  |  |  |  |  |  |  |  |  |  | VNZM |  |  |  |  | 0,3 | 6700 | structure +3.9 |  | HO-21204 | SK1201 |  | 2011-01-09 |  | 2011-02-01 |  |  |  |  |  |  |  |  |
| HO-21205 |  | OVERHEAD TRAVELLING CRANE (for P-21201A) |  | 3.75d | 2011-10-17 | 2011-10-20 | XB001201 SS, XN201201l, XB001201 FF, P3A12S4 (other project) FS+20d |  |  |  |  | -30.75d | 14.25d |  |  | Static Equipment < 10 tons [0.3 t]; Static equipment < 10t [30 h] | 1,200 |  | 30,00 | HO-21205 |  | 30 | 0 |  |  | 12 |  |  |  |  | EQ | X | B |  | 1201 |  |  |  |  |  |  |  |  |  |  |  |  | VNZM |  |  |  |  | 0,3 | 6700 | structure +3.9 |  | HO-21205 | SK1201 |  | 2011-01-09 |  | 2011-02-01 |  |  |  |  |  |  |  |  |
| HO-21206 |  | OVERHEAD TRAVELLING CRANE (for P-21201B) |  | 3.75d | 2011-10-17 | 2011-10-20 | XN201201l, XB001201 FF, P3A12S4 (other project) FS+20d, XB001201 SS |  |  |  |  | -30.75d | 14.25d |  |  | Static Equipment < 10 tons [0.3 t]; Static equipment < 10t [30 h] | 1,200 |  | 30,00 | HO-21206 |  | 30 | 0 |  |  | 12 |  |  |  |  | EQ | X | B |  | 1201 |  |  |  |  |  |  |  |  |  |  |  |  | VNZM |  |  |  |  | 0,3 | 6700 | structure +3.9 |  | HO-21206 | SK1201 |  | 2011-01-09 |  | 2011-02-01 |  |  |  |  |  |  |  |  |
| HO-21208 |  | OVERHEAD TRAVELLING CRANE (Manual Trolley hand geared) |  | 3.75d | 2011-10-17 | 2011-10-20 | XB001201 SS, XB001201 FF, P3A12S4 (other project) FS+20d |  |  |  |  | -0.75d | 73.25d |  |  | Static Equipment < 10 tons [0.3 t]; Static equipment < 10t [30 h] | 1,200 |  | 30,00 | HO-21208 |  | 30 | 0 |  |  | 12 |  |  |  |  | EQ | X | B |  | 1201 |  |  |  |  |  |  |  |  |  |  |  |  | VNZM |  |  |  |  | 0,3 | 6700 |  |  | HO-21208 | SK1201 |  | 2011-01-09 |  | 2011-02-01 |  |  |  |  |  |  |  |  |
| HO-21209 |  | OVERHEAD TRAVELLING CRANE |  | 3.75d | 2011-10-17 | 2011-10-20 | XB001201 SS, XB001201 FF, P3A12S4 (other project) FS+20d |  |  |  |  | -0.75d | 73.25d |  |  | Static Equipment < 10 tons [0.3 t]; Static equipment < 10t [30 h] | 1,200 |  | 30,00 | HO-21209 |  | 30 | 0 |  |  | 12 |  |  |  |  | EQ | X | B |  | 1201 |  |  |  |  |  |  |  |  |  |  |  |  | VNZM |  |  |  |  | 0,3 | 6700 |  |  | HO-21209 | SK1201 |  | 2011-01-09 |  | 2011-02-01 |  |  |  |  |  |  |  |  |
| HO-21210 |  | OVERHEAD TRAVELLING CRANE |  | 5d | 2011-10-17 | 2011-10-21 | XN201201u, XB001201 FF, XN201201l, XB001201 SS, P3A12S4 (other project) FS+20d |  |  |  |  | -2d | 72d |  |  |  |  |  |  | HO-21210 |  | 0 | 0 |  |  | 12 |  |  |  |  | EQ | X | B |  | 1201 |  |  |  |  |  |  |  |  |  |  |  |  | VNZM |  |  |  |  |  | 6700 | structure +23.0 |  | HO-21201 | SK1201 |  | 2011-01-09 |  | 2011-02-01 |  |  |  |  |  |  |  |  |
| V-22221 |  | INSTRUMENT AIR VESSEL |  | 10d | 2011-10-21 | 2011-11-01 | P3A02CS1 (other project), XN601301, XC201300, XN201301u, XN201301l, ER291300 (other project), V-22223, AG-22201-MI01 |  |  |  |  | -71d | 0d |  |  | Static Equipment < 10 tons [1 t]; Static equipment < 10t [100 h] | 4,000 |  | 100,00 | V-22221 | x | 100 | 0 |  |  | 13 |  |  |  |  | EQ | X | B |  | 1301 |  |  |  |  |  |  |  |  |  |  |  |  | VNZM |  |  |  |  | 1 | 1200 | structure | 2 DD 8530 | V-22222 | SK1201 | 2010-10-02 | 2010-11-30 | 2011-02-10 | 2010-12-23 |  | Linde E. India |  |  |  |  |  |  |
| MI-21202 |  | REACTOR FINES EDUCTOR |  | 10d | 2011-10-25 | 2011-11-05 | XN601201, XB001201 SS, XN201201u FS+20d, ER291200 (other project), AG-21201-MI01, P3A07S1 (other project), XB001201 FF |  |  |  |  | -14d | 54d |  |  | Static Equipment < 10 tons [0.25 t]; Static equipment < 10t [25 h] | 1,000 |  | 25,00 | MI-21202 |  | 25 | 0 |  |  | 12 |  |  |  |  | EQ | X | B |  | 1201 |  |  |  |  |  |  |  |  |  |  |  |  | VNZM |  |  |  |  | 0,25 | 1900 | concrete +20.00 |  | MI-21202 | SK1201 |  |  |  |  |  | BERTIN |  |  |  |  | Intall Heat Tracing ET50 |  |
| MI-21801 |  | TEAL STRIPPING COLUMN INTERNAL |  | 12.5d | 2011-10-25 | 2011-11-09 | XN601201, XB001201 FF, ER291200 (other project), XN201201u FS+20d, XB001201 SS |  |  |  |  | -16.5d | 57.5d |  |  | Static equipment < 10t [100 h]; Static Equipment < 10 tons [1 t] | 4,000 |  | 100,00 | MI-21801 |  | 100 | 0 |  |  | 12 |  |  |  |  | EQ | X | B |  | 1201 |  |  |  |  |  |  |  |  |  |  |  |  | VNZM |  |  |  |  |  | 1000 |  | 2 DD 8530 | MI-21801 | SK1201 | 2010-10-02 | 2010-11-30 | 2011-02-10 | 2011-03-10 |  | Linde E. India |  |  |  |  |  |  |
| V-21222 |  | INSTRUMENT AIR VESSEL |  | 10d | 2011-10-29 | 2011-11-10 | ER291200 (other project), XN201201u, XN601201, XC20120105, XB001201 FF, XB001201 SS, P3A02CS1 (other project) FS+20d |  |  |  |  | -38d | 34d |  |  | Static Equipment < 10 tons [1.2 t]; Static equipment < 10t [120 h] | 4,800 |  | 120,00 | V-21222 |  | 120 | 0 |  |  | 12 |  |  |  |  | EQ | X | B |  | 1201 |  |  |  |  |  |  |  |  |  |  |  |  | VNZM |  |  |  |  | 1,2 | 1200 | concrete +0.00 | 2 DD 8530 | V-21222 | SK1201 | 2010-10-02 | 2010-11-30 | 2011-02-10 | 2010-12-23 |  | Linde E. India |  |  |  |  |  |  |
| V-21223 |  | INSTRUMENT AIR VESSEL |  | 10d | 2011-10-29 | 2011-11-10 | XC20120105, XN601201, ER291200 (other project), XB001201 SS, P3A02CS1 (other project) FS+20d, XB001201 FF, XN201201l |  |  |  |  | -38d | 0d |  |  | Static Equipment < 10 tons [1.35 t]; Static equipment < 10t [135 h] | 5,400 |  | 135,00 | V-21223 |  | 135 | 0 |  |  | 12 |  |  |  |  | EQ | X | B |  | 1201 |  |  |  |  |  |  |  |  |  |  |  |  | VNZM |  |  |  | after st.stru. lower part, befor st.stru. upper part | 1,35 | 1350 | concrete +9.00 | 2 DD 8530 | V-21223 | SK1201 | 2010-10-02 | 2010-11-30 | 2011-02-10 | 2010-12-23 |  | Linde E. India |  |  |  |  |  |  |
| V-21221 |  | INSTRUMENT AIR VESSEL |  | 10d | 2011-11-11 | 2011-11-22 | XN601201, XN201201l, AG-21201-MI01, P3A02CS1 (other project) FS+20d, XB001201 SS, V-21223, ER291200 (other project), XB001201 FF, C-21801 |  |  |  |  | -33d | 39d |  |  | Static Equipment < 10 tons [1 t]; Static equipment < 10t [100 h] | 4,000 |  | 100,00 | V-21221 |  | 100 | 0 |  |  | 12 |  |  |  |  | EQ | X | B |  | 1201 |  |  |  |  |  |  |  |  |  |  |  |  | VNZM |  |  |  |  | 1 | 1000 | structure | 2 DD 8530 | V-21221 | SK1201 | 2010-10-02 | 2010-11-30 | 2011-02-10 | 2010-12-23 |  | Linde E. India |  |  |  |  |  |  |
| E-21203 |  | REACTOR START-UP GAS HEATER |  | 20d | 2011-11-28 | 2011-12-20 | XB001201 FF, ER291200 (other project), XB001201 SS, XN201201u, P3A06S1 (other project) FS+50d |  |  |  |  | -72d | 0d |  |  | Static Equipment < 10 tons [1.9 t]; Static equipment < 10t [190 h] | 7,600 |  | 190,00 | E-21203 |  | 190 | 0 |  |  | 12 |  |  |  |  | EQ | X | B |  | 1201 |  |  |  |  |  |  |  |  |  |  |  |  | VNZM |  |  |  |  | 1,9 | 1900 | concrete +2.250 | 2 DD 8530 | E-21203 | SK1201 | 2010-10-02 | 2010-11-30 | 2011-02-10 | 2011-02-10 |  | Linde E. India |  |  |  |  | Intall Heat Tracing ET100 |  |
| CY-21202 |  | FIRST REACTOR OFFGAS CYCLONE |  | 15d | 2011-12-21 | 2012-01-13 | XN601201, V-21201, V-21222, AG-22201-MI01, XB001201 FF, C-21801, V-21223, P-21201A/B, XB001201 SS, XN201201u FS+20d, E-21203, R-21201, P3A04S1 (other project), AG-21201-MI01, ER291200 (other project) |  |  |  |  | -72d | 0d |  |  | Static Equipment < 10 tons [7.17 t]; Static equipment < 10t [717 h] | 28,680 |  | 717,00 | CY-21202 | diff name in cb | 717 | 0 |  |  | 12 |  |  |  |  | EQ | X | B |  | 1201 |  |  |  |  |  |  |  |  |  |  |  |  | VNZM |  |  |  |  | 7,17 | 7170 | structure +26.00 | 2 DC 859 | CY-21202 | SK1201 | 2010-06-30 | 2010-10-01 | 2010-11-01 | 2011-02-10 | 1103 | Facet |  |  |  |  | Intall Heat Tracing ET120 |  |
| HO-21207 |  | OVERHEAD TRAVELLING CRANE |  | 5d | 2011-12-29 | 2012-01-10 | XC40122110, P3A12S4 (other project), XB001221 SS, XB001221 FF |  |  |  |  | -3d | 57d |  |  | Static Equipment < 10 tons [0.3 t]; Static equipment < 10t [30 h] | 1,200 |  | 30,00 | HO-21207 |  | 30 | 0 |  |  | 12 |  |  |  |  | EQ | X | B |  | 1221 |  |  |  |  |  |  |  |  |  |  |  |  | VNZM |  |  |  |  | 0,3 | 6700 | concrete +16.00 |  | HO-21207 | SK1221 |  | 2011-01-09 |  | 2011-02-01 |  |  |  |  |  |  |  |  |
| HO-22207 |  | OVERHEAD TRAVELLING CRANE |  | 5d | 2011-12-29 | 2012-01-10 | XC40132110, P3A12S5 (other project), XB001321 SS, XB001321 FF |  |  |  |  | -38d | 25d |  |  | Static Equipment < 10 tons [0.3 t]; Static equipment < 10t [30 h] | 1,200 |  | 30,00 | HO-22207 |  | 30 | 0 |  |  | 13 |  |  |  |  | EQ | X | B |  | 1321 |  |  |  |  |  |  |  |  |  |  |  |  | VNZM |  |  |  |  | 0,3 | 6700 | concrete +16.00 |  | HO-22207 | SK1321 |  | 2011-01-09 |  | 2011-02-01 |  |  |  |  |  |  |  |  |
| V-21224 |  | INSTRUMENT AIR VESSEL |  | 5d | 2012-01-14 | 2012-01-19 | XN601201, XB001201 SS, C-21801, CY-21202, P-21201A/B, XN201201u, XB001201 FF, V-21222, P3A02CS1 (other project) FS+20d, ER291200 (other project), AG-21201-MI01, V-21221, V-21223 |  |  |  |  | -72d | 2d |  |  | Static Equipment < 10 tons [0.15 t]; Static equipment < 10t [15 h] | 600 |  | 15,00 | V-21224 |  | 15 | 0 |  |  | 12 |  |  |  |  | EQ | X | B |  | 1201 |  |  |  |  |  |  |  |  |  |  |  |  | VNZM |  |  |  |  | 0,15 | 1000 | structure | 2 DD 8530 | V-21224 | SK1201 | 2010-10-02 | 2010-11-30 | 2011-02-10 | 2010-12-23 |  | Linde E. India |  |  |  |  |  |  |
| HE-21108 |  | MINERAL OIL HEATER (electrical) |  | 5d | 2012-02-20 | 2012-02-25 | P3A06AS2 (other project), XB001221 FF, XB001221 SS, V-21108 |  |  |  |  | -37d | 23d |  |  | Static Equipment < 10 tons [0.1 t]; Static equipment < 10t [10 h] | 400 |  | 10,00 | HE-21108 |  | 10 | 0 |  |  | 12 |  |  |  |  | EQ | X | B |  | 1221 |  |  |  |  |  |  |  |  |  |  |  |  | VNZM |  |  |  |  | 0,1 | 1000 | structure | 2 DD 8530 | HE-21108 | SK1221 | 2010-10-02 | 2010-11-30 | 2011-02-10 | 2010-12-23 |  | Linde E. India |  |  |  |  |  |  |
| V-22224 |  | INSTRUMENT AIR VESSEL |  | 5d | 2012-05-02 | 2012-05-07 | V-22221, P-22201A/B, V-22222 (other project), CY-22202, ER291300 (other project), V-22223, AG-22201-MI01, P3A02CS1 (other project), XN201301u, XN601301 |  |  |  |  | -58d | 0d |  |  | Static Equipment < 10 tons [0.15 t]; Static equipment < 10t [15 h] | 600 |  | 15,00 | V-22224 |  | 15 | 0 |  |  | 13 |  |  |  |  | EQ | X | B |  | 1301 |  |  |  |  |  |  |  |  |  |  |  |  | VNZM |  |  |  |  | 0,15 | 1000 | structure | 2 DD 8530 | V-21224 | SK1201 | 2010-10-02 | 2010-11-30 | 2011-02-10 | 2010-12-23 |  | Linde E. India |  |  |  |  |  |  |
| V-21320 |  | INSTRUMENT AIR VESSEL |  | 2.5d | 2012-05-26 | 2012-05-29 | XR401110, XC20111010, XN201110, XB001110 FF, P3A02CS2 (other project), XB001110 SS, ER291100 (other project) |  |  |  |  | -117.5d | 0d |  |  | Static Equipment < 10 tons [0.15 t]; Static equipment < 10t [15 h] | 600 |  | 15,00 | V-21320 |  | 15 | 0 |  |  | 11 |  |  |  |  | EQ | X | B |  | 1110 |  |  |  |  |  |  |  |  |  |  |  |  |  |  |  |  |  | 0,15 | 1000 | concrete +0.00 |  | V-21320 | SK1110 | 2010-10-02 | 2010-11-30 | 2011-02-10 | 2010-12-23 |  |  |  |  |  |  |  |  |
| V-22320 |  | INSTRUMENT AIR VESSEL |  | 2.5d | 2012-05-26 | 2012-05-29 | P3A02CS2 (other project), ER291100 (other project), XN201110, XB001110 SS, XR401110, XC20111010, XB001110 FF |  |  |  |  | -117.5d | 0d |  |  | Static Equipment < 10 tons [0.15 t]; Static equipment < 10t [15 h] | 600 |  | 15,00 | V-22320 |  | 15 | 0 |  |  | 11 |  |  |  |  | EQ | X | B |  | 1110 |  |  |  |  |  |  |  |  |  |  |  |  |  |  |  |  |  | 0,15 | 1000 | concrete +0.00 |  | V-22320 | SK1110 | 2010-10-02 | 2010-11-30 | 2011-02-10 | 2010-12-23 |  |  |  |  |  |  |  |  |

Notes:
- XN711201: Scope: 09.02.2011: weight: 86 ton - Nov 2 ton, Dec 47 / ton, Jan 37 ton
- XN731201: Scope: 09.02.2011: weight: 265 ton - Jan 97 ton, Feb 80 ton, Mar 88 ton / (mit der Annahme, dass 17,6 t pro Tag verbaut werden mьssen, benцtigt der / Subkontraktor noch 6 Tage, um die Tonnage der letzten Lieferungen (88 t am / 06.03) verbauen zu kцnnen.)
- XN711200: Current Status: 12.04.2011 (O.Siegel): fьr den "lower part" 99,17% des Stahls / gelieferert
- XN751201: Current Status: 12.04.2011 (O.Siegel): fьr den "upper part" 20,27% des Stahls / gelieferert
- XN601201: Current Status: 12.04.2011 (O.Siegel): 21,74% des Gratings / gelieferert
- XN401201: Current Status: 17.05.2011 (O.Siegel): zum heutigen / Zeitpunkt wurden noch keine Railing and Ladders geliefert.
- R-21201: UDF_PACKAGE: ALL1 REACTORS WITH AGITATORS R-21-/22201)
- V-21201: UDF_PACKAGE: ALL2 PURGE COLUMNS / REACTOR OVERHEAD SEPARATORS (C-21-/22304, V-21-/22304)
- AG-21201-MI01: UDF_PACKAGE: M11 REACTOR AGITATOR GEAR UNIT (AG-21-/22201-MI01)
- E-21206: UDF_PACKAGE: A04A REACTOR OVERHEAD CONDENSERS (E-21-/22206)
- HO-22203: UDF_PACKAGE: A12 OVERHEAD CRANES / TROLLEYS (incl. in Civil Subcontract)
- HO-22204: UDF_PACKAGE: A12 OVERHEAD CRANES / TROLLEYS (incl. in Civil Subcontract)
- HO-22205: UDF_PACKAGE: A12 OVERHEAD CRANES / TROLLEYS (incl. in Civil Subcontract)
- HO-22206: UDF_PACKAGE: A12 OVERHEAD CRANES / TROLLEYS (incl. in Civil Subcontract)
- HO-22208: UDF_PACKAGE: A12 OVERHEAD CRANES / TROLLEYS (incl. in Civil Subcontract)
- HO-22209: UDF_PACKAGE: A12 OVERHEAD CRANES / TROLLEYS (incl. in Civil Subcontract)
- HO-22202: UDF_PACKAGE: A12 OVERHEAD CRANES / TROLLEYS (incl. in Civil Subcontract)
- MI-22202: UDF_PACKAGE: A07 REACTOR FINES EDUCATOR (MI-21-/22202)
- V-22222: UDF_PACKAGE: A02C INSTRUMENT AIR VESSELS
- C-21801: UDF_PACKAGE: A01 PRESSURE EQUIPMENT
- V-22223: UDF_PACKAGE: A02C INSTRUMENT AIR VESSELS
- HO-21201: UDF_PACKAGE: A12 OVERHEAD CRANES / TROLLEYS (incl. in Civil Subcontract)
- HO-21202: UDF_PACKAGE: A12 OVERHEAD CRANES / TROLLEYS (incl. in Civil Subcontract)
- HO-21203: UDF_PACKAGE: A12 OVERHEAD CRANES / TROLLEYS (incl. in Civil Subcontract)
- HO-21204: UDF_PACKAGE: A12 OVERHEAD CRANES / TROLLEYS (incl. in Civil Subcontract)
- HO-21205: UDF_PACKAGE: A12 OVERHEAD CRANES / TROLLEYS (incl. in Civil Subcontract)
- HO-21206: UDF_PACKAGE: A12 OVERHEAD CRANES / TROLLEYS (incl. in Civil Subcontract)
- HO-21208: UDF_PACKAGE: A12 OVERHEAD CRANES / TROLLEYS (incl. in Civil Subcontract)
- HO-21209: UDF_PACKAGE: A12 OVERHEAD CRANES / TROLLEYS (incl. in Civil Subcontract)
- HO-21210: UDF_PACKAGE: A12 OVERHEAD CRANES / TROLLEYS (incl. in Civil Subcontract)
- V-22221: UDF_PACKAGE: A02C INSTRUMENT AIR VESSELS
- MI-21202: UDF_PACKAGE: REACTOR FINES EDUCATOR (MI-21-/22202)
- MI-21801: UDF_PACKAGE: A17 COLUMN INTERNALS (MI-21801)
- V-21222: UDF_PACKAGE: A02C INSTRUMENT AIR VESSELS
- V-21223: UDF_PACKAGE: A02C INSTRUMENT AIR VESSELS
- V-21221: UDF_PACKAGE: A02C INSTRUMENT AIR VESSELS
- E-21203: UDF_PACKAGE: A06 R.START-UP GAS HEATER/STEAM CONDENSER (E-21-/22203/21901)
- CY-21202: UDF_PACKAGE: A05 OFFGAS CYCLONE, RECEIVER & TRANSITION PIECES (CY-21-/22202)
- HO-21207: UDF_PACKAGE: A12 OVERHEAD CRANES / TROLLEYS (incl. in Civil Subcontract)
- HO-22207: UDF_PACKAGE: A12 OVERHEAD CRANES / TROLLEYS (incl. in Civil Subcontract)
- V-21224: UDF_PACKAGE: A02C INSTRUMENT AIR VESSELS
- HE-21108: UDF_PACKAGE: A06A NITROGEN / MINERAL OIL HEATER (ELECTRiCAL)
- V-22224: UDF_PACKAGE: A02C INSTRUMENT AIR VESSELS
- V-21320: UDF_PACKAGE: A02C INSTRUMENT AIR VESSELS
- V-22320: UDF_PACKAGE: A02C INSTRUMENT AIR VESSELS

| ID | WBS | Activity | Type | Duration | Start | Finish | Predecessors | Complete | Remaining | Planned start | Planned finish | Total float | Free float | Constraint | Calendar | Resources | Cost | Actual cost | TB26 Ressource Budget | Comments | Drawing Indicator | UDF_CONTRACT START DATE | UDF_CONTRACT FINISH DATE | UDF_CONTRACT ITEM | UDF_SAVE ACT ID | UDF_BUDGETED LABOR UNIT | UDF_ACTUAL LABOR UNIT | Department | Type of Work | Constr. Area | PMT-Area | PMT-Schedule Org | PMT-Phase | PMT-Respons. | WBS Phase | WBS Discipline | WBS Type of Work | WBS Objects | Russia WBS Discipline (Russia) | Russia Construction Area | Russia WBS Phase | IMS | UPT | Russia WBS Objects | Subcontractor | UDF_Weight (ton) | WEIGHT | UDF_LEVEL | UDF_PO No | UDF_TAG No | UDF_Object No | UDF_DELIVERY DATE PO | UDF_DELIVERY DATE DISPATCH PLANNED | UDF_DELIVERY DATE TO SITE PLANNED | UDF_DELIVERY DATE SITE NEED DATE | UDF_PACKAGE | UDF_SUPPLIER | Zeigen/n. Zeigen | UDF_CONTRACT INDICATOR | UDF_SELECT UPDATE PROGRESS | UDF_CHECK RESOURCE DATES | UDF_PLANNED START | UDF_PLANNED FINISH | TB26 Semantics | TB26 Material Res Values | UDF_ELECTRICAL START | UDF_ELECTRICAL FINISH | UDF_CONTRACT FINISH DATE REV1 | UDF_CONTRACT START DATE REV1 | UDF_CHECK BASELINE | UDF_Vendor Representatives | UDF_COMMENTS_0827 | UDF_PENALIZED FINISH |
| --- | --- | --- | --- | --- | --- | --- | --- | --- | --- | --- | --- | --- | --- | --- | --- | --- | --- | --- | --- | --- | --- | --- | --- | --- | --- | --- | --- | --- | --- | --- | --- | --- | --- | --- | --- | --- | --- | --- | --- | --- | --- | --- | --- | --- | --- | --- | --- | --- | --- | --- | --- | --- | --- | --- | --- | --- | --- | --- | --- | --- | --- | --- | --- | --- | --- | --- | --- | --- | --- | --- | --- | --- | --- |
|  | M | **Mechanical - Rotating Equipment** |  |  | 2011-05-25 | 2011-10-24 |  |  |  |  |  |  |  |  |  |  |  |  |  |  |  |  |  |  |  |  |  |  |  |  |  |  |  |  |  |  |  |  |  |  |  |  |  |  |  |  |  |  |  |  |  |  |  |  |  |  |  |  |  |  |  |  |  |  |  |  |  |  |  |  |  |  |  |
| XM001201 |  | CA12 ReactorStruc - Install Rotating Eqpt | level of effort | 15d | 2011-05-25 A | 2011-06-10 A |  | 100% |  |  |  |  |  |  |  |  |  |  | 32 | E-08-01-07 | UDF_G2 | 2011-02-10 | 2011-04-30 | E-08-01-07 | XM001201 | 0 | 0 | 934 | XBB | 12 | 200 | 200 | C | LND | X | M | XM00 | 1201 | M | 12 | X | EQ | LND | 1201 | VNZM |  |  |  |  |  |  |  |  |  |  |  |  |  |  |  |  |  |  |  |  |  |  |  |  |  |  |  |  |
| PK-21211 |  | REACTOR SEAL OIL PACKAGE |  | 20d | 2011-10-01 | 2011-10-24 | XN201201u, XN601201, XB001201 SS, P3U15S1 (other project) FS+20d, ER291200 (other project), XB001201 FF |  |  |  |  | -4d | 64d |  |  | Static equipment < 10t [500 h]; Static Equipment < 10 tons [5 t] | 20,000 |  | 500,00 | Intall Heat Tracing ET40 |  |  |  |  | PK-21211 | 500 | 0 |  |  | 12 |  |  |  |  | X | B |  | 1201 |  |  |  |  |  |  | VNZM | 5 | 5000 | concrete +0.00 | 2 DC 8910 | PK-21211 | SK1201 | 2010-11-25 | 2011-01-17 | 2011-01-30 | 2011-02-10 | PU15 REACTOR SEAL OIL PACKAGE | COEK | EQ |  |  |  |  |  |  |  |  |  |  |  |  |  |  |  |
| PK-22211 |  | REACTOR SEAL OIL PACKAGE |  | 20d | 2011-10-01 | 2011-10-24 | XN601301, XN201301u, ER291300 (other project), P3U15S2 (other project) |  |  |  |  | -54d | 30d |  |  | Static Equipment < 10 tons [5 t]; Static equipment < 10t [500 h] | 20,000 |  | 500,00 |  |  |  |  |  | PK-22211 | 500 | 0 |  |  | 13 |  |  |  |  | X | B |  | 1301 |  |  |  |  |  |  | VNZM | 5 | 5000 | concrete +0.00 | 2 DC 8910 | PK-22211 | SK1301 | 2010-11-25 | 2011-01-17 | 2011-01-30 | 2011-02-10 | PU15 REACTOR SEAL OIL PACKAGE | COEK | EQ |  |  |  |  |  |  |  |  |  |  |  |  |  |  |  |
|  | R | **Piping** |  |  | 2011-02-24 | 2012-04-02 |  |  |  |  |  |  |  |  |  |  |  |  |  |  |  |  |  |  |  |  |  |  |  |  |  |  |  |  |  |  |  |  |  |  |  |  |  |  |  |  |  |  |  |  |  |  |  |  |  |  |  |  |  |  |  |  |  |  |  |  |  |  |  |  |  |  |  |
| XR201201 |  | CA12 ReactorStruc SK1201- Piping Prefabrication |  | 186d | 2011-02-24 A | 2011-10-03 | P3R06DS (other project), ER491201 (other project) SS+12d, XR400C20 SF, P3R06S (other project) |  | 32d |  |  | 34d | 59d |  |  | A/G piping prefabrication [6300 Fpi]; A/G Piping (Prefab) [23625 h] | 22,937.6 |  | 23625,00 |  |  |  |  |  | XR201201 | 23625 | 6105 | 934 |  | 12 | 200 | 200 | C | LND | X | R | XR20 | 1201 | R | 12 | X | PRP | LND | 1201 | VNZM |  |  |  |  |  |  |  |  |  |  |  |  |  | UDF_G4 | 27.8. | x |  |  |  |  |  |  |  |  |  |  |  |  |
| XR401201 |  | CA12 ReactorStruc SK1201- Piping Installation (Start with Pipe Rack) |  | 140d | 2011-09-01 | 2012-02-18 | P3R09BS (other project) FF+20d, P3R04AS (other project) FF+20d, P3J02S (other project) FF+20d, P3S01S (other project) FF+20d, V-21222 FF, MI-21202 FF, P3J04CS1 (other project), AG-21201-MI01 SS+12d, CY-21202 FF, AG-21201, P3R07AS1 (other project), P3R04S (other project) FF+20d, P3R07BS (other project) FF+30d, P3J02CS (other project), E-21206, MI-21801 FF, V-21223 FF, XN801201 FF+20d, V-21221 FF, V-21224 FF, XR201201 FS-90d, P3A25S (other project) FF+20d, P3R04S1 (other project) FF+20d, P3J01S (other project), C-21801 FF, E-21203 FF, PK-21211 FF, P3R07AS (other project), P3R03BS1 (other project) FF+20d, P3R03AS1 (other project) FF+20d, P3J02AS (other project) FF+20d, P3J04IS (other project) FF+20d, P3S02S (other project) FF+20d, P3J01AS (other project) FF+20d, P3J02DS (other project) FF+20d |  |  |  |  | -28d | 0d | start on or after 2011-09-01 |  | A/G piping field installation [7700 Fpi]; Control & Shut-off valves [106 pcs]; Install Control & Shut-off Valves [556.5 h]; A/G Piping (Field) [48125 h]; Deluge piping [18750 h]; Deluge Piping [3000 Fpi] | 853,825.75 |  | 67431,50 |  |  | 2011-01-10 |  | E-06-03-03 | XR401201 | 67431,5 | 0 | 934 |  | 12 | 200 | 200 | C | LND | X | R | XR40 | 1201 | R | 12 | X | PI | LND | 1201 | VNZM |  |  |  |  |  |  |  |  |  |  |  |  |  | UDF_G4 |  |  | 2011-04-06 |  |  |  |  |  |  |  |  |  |  |  |
| XR601201 |  | CA12 ReactorStruc SK1201- Piping Pressure Test |  | 90d | 2011-11-29 | 2012-03-21 | XR401201 FF+20d, XR605102 FF+20d, X0300020 |  |  |  |  | -12d | 0d |  |  |  |  |  | 1689 |  |  |  |  | E-06-03-03 | XR601201 | 0 | 0 | 934 |  | 12 | 200 | 200 | C | LND | X | R | XR60 | 1201 | R | 12 | X | HY | LND | 1201 | VNZM |  |  |  |  |  |  |  |  |  |  |  |  |  |  |  |  |  |  |  |  |  |  |  |  |  |  |  |  |
| XR801201 |  | CA12 ReactorStruc SK1201- Piping Reinstatement |  | 70d | 2012-01-10 | 2012-04-02 | XR601201 FF+10d, IMS-C-000360 FF |  |  |  |  | -12d | 30d |  |  |  |  |  | 844 |  |  |  | 2011-10-30 | E-06-03-03 | XR801201 | 0 | 0 | 934 |  | 12 | 200 | 200 | C | LND | X | R | XR80 | 1201 | R | 12 | X | PI | LND | 1201 | VNZM |  |  |  |  |  |  |  |  |  |  |  |  |  |  |  |  |  | 2012-01-30 |  |  |  |  |  |  |  |  |  |  |
|  | E | **Electrical** |  |  | 2010-06-28 | 2012-09-12 |  |  |  |  |  |  |  |  |  |  |  |  |  |  |  |  |  |  |  |  |  |  |  |  |  |  |  |  |  |  |  |  |  |  |  |  |  |  |  |  |  |  |  |  |  |  |  |  |  |  |  |  |  |  |  |  |  |  |  |  |  |  |  |  |  |  |  |
| XC911201 |  | CA12 ReactorStruc - Install Earthing&Lightn.Sys_CIVIL |  | 35d | 2010-06-28 A | 2010-08-06 A | XC20120105 FF+10d, EE900010 (other project), EE901201 (other project) | 100% |  |  |  |  |  |  | TB26 - V - Construct-Winter partly * | Grounding & Lightning [230 pcs]; Grounding & Lightning [2587.5 h] | 103,500 | 103,500 | 2587,50 |  |  |  | 2011-10-30 |  | XC911201 | 2587,5 | 2587,5 | 934 |  | 12 | 200 | 200 | C | LND | X | C | XE91 | 1201 | C | 12 | X | EA | LND | 1201 | MO11 |  |  |  |  |  |  |  |  |  |  |  |  |  |  |  |  |  |  |  |  |  |  |  |  |  |  |  |  |
| XE401201 |  | CA12 ReactorStruc - Install Cable Trays (Start with Pipe Rack 1201) |  | 70d | 2011-07-29 A | 2011-10-05 | P3E16S (other project), XE405102 SS+12d, EE46510120 (other project) FF, EE46120110 (other project), XN201201u |  | 34d | 2011-07-29 | 2011-10-18 | 6d | 78d |  | TB26 - V - Construct-Winter partly * | Cable trays/conduits [870 m]; Cable trays [2610 h] | 104,400 | 44,237.29 | 2610,00 |  |  | 2011-05-20 | 2011-07-20 | E-15-01-08 | XE401201 | 2610 | 0 | 934 |  | 12 | 200 | 200 | C | LND | X | E | XE40 | 1201 | E | 12 | X | EL | LND | 1201 | URMA |  |  |  |  |  |  |  |  |  |  |  |  |  | UDF_G3 | 27.8. | ok |  |  | m | 1450 | 2011-05-21 | 2011-08-11 | 2011-11-10 | 2011-07-11 | x |  |  |  |
| XE801201 |  | CA12 ReactorStruc - Install Heat Tracing |  | 100d | 2012-01-16 | 2012-06-09 | C-21801, MI-21202, AG-21201, E3E1950 (other project), P3E19S (other project), CY-21202, E-21203, XR401201 FF+40d, AG-21201-MI01 SS+40d, PK-21211, XW501201 SS+15d, XR601201 FF+45d |  |  |  |  | 17d | 0d |  | TB26 - V - Construct-Winter partly * | Electrical Heat Tracing [2000 m]; Electrical heat tracing [1000 h] | 40,000 |  | 1000,00 |  |  | 2011-06-20 | 2012-03-20 | E-16-04-01 | XE801201 | 1000 | 0 | 934 |  | 12 | 200 | 200 | C | LND | X | E | XE80 | 1201 | E | 12 | X | HT | LND | 1201 | URMA |  |  |  |  |  |  |  |  |  |  |  |  |  | UDF_G3 |  |  |  |  |  |  |  |  | 2012-06-30 | 2011-09-15 |  | 005 | to be installed later |  |
| XE911205 |  | CA12 ReactorStruc - Install Earthing&Lightn.Sys_E/I |  | 20d | 2012-01-23 | 2012-03-02 | XN201201u, AG-21201, C-21801, CY-21202, E-21203, E-21206, HO-21201, HO-21202, HO-21203, HO-21204, HO-21205, HO-21206, HO-21208, HO-21209, HO-21210, MI-21202, MI-21801, PK-21211, R-21201, V-21201, V-21221, V-21222, V-21223, V-21224, AG-21201-MI01 |  |  |  |  | 94d | 156.5d |  | TB26 - V - Construct-Winter partly * |  |  |  | 260 |  |  | 2011-05-20 | 2011-10-30 | E-16-07-02 | XE911205 | 0 | 0 | 934 |  | 12 | 200 | 200 | C | LND | X | E | XE91 | 1201 | E | 12 | X | EA | LND | 1201 | URMA |  |  |  |  |  |  |  |  |  |  |  |  |  | UDF_G3 |  |  |  |  |  |  |  |  | 2012-05-30 | 2011-07-10 |  |  |  |  |
| XE341201 |  | CA12 ReactorStruc - Install Local Operation Panels |  | 50d | 2012-04-14 | 2012-06-14 | XJ421201 FS-20d, XE401201, EE46120110 (other project), XR401201 SS+70d, AG-21201, C-21801, CY-21202, E-21203, E-21206, HO-21201, HO-21202, HO-21203, HO-21204, HO-21205, HO-21206, HO-21208, HO-21209, HO-21210, MI-21202, MI-21801, PK-21211, R-21201, V-21201, V-21221, V-21222, V-21223, V-21224, AG-21201-MI01 |  |  |  |  | -44d | 26.5d |  | TB26 - V - Construct-Winter partly * | Field Panels [14 pcs]; Field panels [280 h] | 11,200 |  | 280,00 |  |  | 2011-05-20 | 2011-10-30 | E-16-07-02 | XE341201 | 280 | 0 | 934 |  | 12 | 200 | 200 | C | LND | X | E | XE34 | 1201 | E | 12 | X | EL | LND | 1201 | URMA |  |  |  |  |  |  |  |  |  |  |  |  |  | UDF_G3 |  |  |  |  |  |  |  |  | 2012-05-30 | 2011-07-10 |  |  | to be installed later |  |
| XE501201 |  | CA12 ReactorStruc - Cable Pulling Electric |  | 60d | 2012-06-09 | 2012-08-20 | XE500C01, P3E15AS (other project), XE401201, P3E15BS (other project), XE505102 SS+10d, P3E15CS (other project), EE561201 (other project), XE505103 SS+10d, XE505401 SS+15d |  |  |  |  | -70.5d | 0d |  | TB26 - V - Construct-Winter partly * | Cable Pulling [14400 m]; Cable pulling [7200 h] | 288,000 |  | 7200,00 |  |  | 2011-05-20 | 2012-02-10 | E-16-01-01 | XE501201 | 7200 | 0 | 934 |  | 12 | 200 | 200 | C | LND | X | E | XE50 | 1201 | E | 12 | X | EL | LND | 1201 | URMA |  |  |  |  |  |  |  |  |  |  |  |  |  | UDF_G3 |  |  |  |  | m | 14900 | 2011-08-20 | 2011-10-28 | 2012-07-01 | 2011-10-01 |  |  |  |  |
| XE601201 |  | CA12 ReactorStruc - Cable Termination & Testing |  | 50d | 2012-07-16 | 2012-09-12 | XE501201 FF+20d, XE341201, AG-21201, C-21801, CY-21202, E-21203, E-21206, HO-21201, HO-21202, HO-21203, HO-21204, HO-21205, HO-21206, HO-21208, HO-21209, HO-21210, MI-21202, MI-21801, PK-21211, R-21201, V-21201, V-21221, V-21222, V-21223, V-21224, AG-21201-MI01 |  |  |  |  | -70.5d | 0d |  | TB26 - V - Construct-Winter partly * | Cable connecting [300 pcs]; Cable connecting [750 h] | 30,000 |  | 750,00 |  |  | 2011-04-20 | 2011-11-30 | E-16-02-01 | XE601201 | 750 | 0 | 934 |  | 12 | 200 | 200 | C | LND | X | E | XE60 | 1201 | E | 12 | X | ET | LND | 1201 | URMA |  |  |  |  |  |  |  |  |  |  |  |  |  | UDF_G3 |  |  |  |  |  |  |  |  | 2012-08-14 | 2011-12-10 |  |  |  |  |
|  | J | **Instrumentation** |  |  | 2012-01-23 | 2012-11-30 |  |  |  |  |  |  |  |  |  |  |  |  |  |  |  |  |  |  |  |  |  |  |  |  |  |  |  |  |  |  |  |  |  |  |  |  |  |  |  |  |  |  |  |  |  |  |  |  |  |  |  |  |  |  |  |  |  |  |  |  |  |  |  |  |  |  |  |
| XJ301201 |  | CA12 ReactorStruc - Install Field Instruments |  | 80d | 2012-01-23 | 2012-05-21 | P3J07CS (other project), EJ361201 (other project), P3J03S1 (other project) FF, EJ360010 (other project), XR801201 FF+10d, P3J04BS (other project), P3J05S (other project), P3J04AS (other project), P3J07BS (other project), XR401201 SS+70d, AG-21201, C-21801, CY-21202, E-21203, E-21206, HO-21201, HO-21202, HO-21203, HO-21204, HO-21205, HO-21206, HO-21208, HO-21209, HO-21210, MI-21202, MI-21801, PK-21211, R-21201, V-21201, V-21221, V-21222, V-21223, V-21224, AG-21201-MI01 |  |  |  |  | -41d | 0d |  | TB26 - V - Construct-Winter partly * | Field Instruments [257 pcs]; Install field instruments [1413 h] | 56,540 |  | 1413,00 |  |  | 2011-05-20 | 2012-03-20 | E-17-04-02 | XJ301201 | 1413 | 0 | 934 |  | 12 | 200 | 200 | C | LND | X | J | XJ30 | 1201 | J | 12 | X | IN | LND | 1201 | URMA |  |  |  |  |  |  |  |  |  |  |  |  |  | UDF_G3 |  |  |  |  |  |  |  |  | 2012-08-10 | 2011-08-05 |  |  | to be installed later |  |
| XJ321201 |  | CA12 ReactorStruc - Install Junction Boxes (Start with Pipe Rack 1201) |  | 40d | 2012-01-23 | 2012-04-02 | P3J06ES (other project) FS+14d, P3J06FS (other project) FF, EJ32171005 (other project), XN201201u, EJ321201 (other project), XR401201 SS+70d, AG-21201, C-21801, CY-21202, E-21203, E-21206, HO-21201, HO-21202, HO-21203, HO-21204, HO-21205, HO-21206, HO-21208, HO-21209, HO-21210, MI-21202, MI-21801, PK-21211, R-21201, V-21201, V-21221, V-21222, V-21223, V-21224, AG-21201-MI01 |  |  |  |  | -46d | 0d |  | TB26 - V - Construct-Winter partly * | Junction Boxes/Cabinets/Panels [61 pcs]; Install Junction Boxes/ Cabinets/ Panels [1525 h] | 61,000 |  | 1525,00 |  |  | 2011-05-20 | 2012-03-20 | E-17-04-02 | XJ321201 | 1525 | 0 | 934 |  | 12 | 200 | 200 | C | LND | X | J | XJ32 | 1201 | J | 12 | X | IN | LND | 1201 | URMA |  |  |  |  |  |  |  |  |  |  |  |  |  | UDF_G3 |  |  |  |  |  |  |  |  | 2012-08-10 | 2011-08-05 | x |  | to be installed later |  |
| XJ421201 |  | CA12 ReactorStruc - Install Secondady Cable Trays (Start with Pipe Rack 1201) |  | 50d | 2012-03-05 | 2012-05-09 | EJ46120110 (other project), XJ321201 FS-20d, XE401201, XR401201 SS+70d, AG-21201, C-21801, CY-21202, E-21203, E-21206, HO-21201, HO-21202, HO-21203, HO-21204, HO-21205, HO-21206, HO-21208, HO-21209, HO-21210, MI-21202, MI-21801, PK-21211, R-21201, V-21201, V-21221, V-21222, V-21223, V-21224, AG-21201-MI01 |  |  |  |  | -46d | 0d |  | TB26 - V - Construct-Winter partly * | Secondary cable trays [580 m]; Install secondary cable trays [2175 h] | 87,000 |  | 2175,00 |  |  | 2011-05-20 | 2011-07-20 | E-15-01-08 | XJ421201 | 2175 | 0 | 934 |  | 12 | 200 | 200 | C | LND | X | J | XJ42 | 1201 | J | 12 | X | IN | LND | 1201 | URMA |  |  |  |  |  |  |  |  |  |  |  |  |  |  |  |  |  |  | m | 1070 | 2011-05-21 | 2011-08-11 | 2011-11-10 | 2011-07-11 | x |  | to be installed later |  |
| XJ391201 |  | CA12 ReactorStruc - Install Earthing Field Eqpt |  | 50d | 2012-04-09 | 2012-06-07 | XJ301201 FS-40d, XJ421201 FS-25d |  |  |  |  | -26d | 20d |  | TB26 - V - Construct-Winter partly * |  |  |  |  |  |  | 2011-05-20 | 2012-03-20 | E-17-04-02 | XJ391201 | 0 | 0 | 934 |  | 12 | 200 | 200 | C | LND | X | J | XJ39 | 1201 | J | 12 | X | IN | LND | 1201 | URMA |  |  |  |  |  |  |  |  |  |  |  |  |  | UDF_G3 |  |  |  |  |  |  |  |  | 2012-08-10 | 2011-08-05 |  |  |  |  |
| XJ701201 |  | CA12 ReactorStruc - Instrument Tubing |  | 50d | 2012-04-26 | 2012-06-26 | XR401201, XJ301201 FF+30d |  |  |  |  | -41d | 5d |  | TB26 - V - Construct-Winter partly * |  |  |  |  |  |  | 2011-05-20 | 2012-03-20 | E-17-04-02 | XJ701201 | 0 | 0 | 934 |  | 12 | 200 | 200 | C | LND | X | J | XJ70 | 1201 | J | 12 | X | IN | LND | 1201 | URMA |  |  |  |  |  |  |  |  |  |  |  |  |  |  |  |  |  |  |  |  |  |  | 2012-08-10 | 2011-08-05 |  |  |  |  |
| XJ542101 |  | CA12 ReactorStruc - Pulling Singlecore Cables |  | 70d | 2012-05-10 | 2012-07-31 | XE500C01, XJ421201, EJ801201 (other project), XE401201, XJ301201 FF+40d |  |  |  |  | -46d | 0d |  | TB26 - V - Construct-Winter partly * | Pull singlecore cables [18750 h]; Singlecore cables [25000 m] | 750,000 |  | 18750,00 |  |  | 2011-05-20 | 2012-03-20 | E-17-04-02 | XJ542101 | 18750 | 0 | 934 |  | 12 | 200 | 200 | C | LND | X | J | XJ54 | 1201 | J | 12 | X | IN | LND | 1201 | URMA |  |  |  |  |  |  |  |  |  |  |  |  |  |  |  |  |  |  | m | 23942 | 2011-09-26 | 2012-03-30 | 2012-08-10 | 2011-08-05 |  |  |  |  |
| XJ521201 |  | CA12 ReactorStruc - Pulling Multicore Cables |  | 60d | 2012-05-31 | 2012-08-10 | XJ525102 SS+10d, XE500C01, XJ525401 SS+12d, XJ321201 SS+20d, XE401201 |  |  |  |  | -82.5d | 0d |  | TB26 - V - Construct-Winter partly * | Multicore cables [13100 m]; Pull multicore cables [6550 h] | 262,000 |  | 6550,00 |  |  | 2011-05-20 | 2012-03-10 | E-17-01-01 | XJ521201 | 6550 | 0 | 934 |  | 12 | 200 | 200 | C | LND | X | J | XJ52 | 1201 | J | 12 | X | IN | LND | 1201 | URMA |  |  |  |  |  |  |  |  |  |  |  |  |  |  |  |  |  |  | m | 9500 | 2011-08-23 | 2011-10-31 | 2012-06-16 | 2011-11-01 |  |  | to be checked |  |
| XJ641201 |  | CA12 ReactorStruc - Termin Singlecore Cables |  | 70d | 2012-06-02 | 2012-08-23 | XJ301201, XJ542101 FF+20d, XJ321201, XJ391201 FS-25d, XJ701201 FS-25d |  |  |  |  | -46d | 16.5d |  | TB26 - V - Construct-Winter partly * | Termination Field [2117 mhr]; Termination field [2117 h] | 211,700 |  | 2117,00 |  |  | 2011-05-20 | 2012-03-20 | E-17-04-02 | XJ641201 | 2117 | 0 | 934 |  | 12 | 200 | 200 | C | LND | X | J | XJ64 | 1201 | J | 12 | X | IN | LND | 1201 | URMA |  |  |  |  |  |  |  |  |  |  |  |  |  |  |  |  |  |  |  |  |  |  | 2012-08-10 | 2011-08-05 |  |  |  |  |
| XJ621201 |  | CA12 ReactorStruc - Termin Multicore Cables |  | 60d | 2012-06-25 | 2012-09-03 | XJ321201, XJ521201 FF+20d |  |  |  |  | 178d |  |  | TB26 - V - Construct-Winter partly * | Termination Field [2118 mhr]; Termination field [2118 h] | 211,800 |  | 2118,00 |  |  | 2011-05-20 | 2012-03-10 | E-17-01-01 | XJ621201 | 2118 | 0 | 934 |  | 12 | 200 | 200 | C | LND | X | J | XJ62 | 1201 | J | 12 | X | IN | LND | 1201 | URMA |  |  |  |  |  |  |  |  |  |  |  |  |  |  |  |  |  |  |  |  |  |  | 2012-06-16 | 2011-11-01 |  |  | to be checked |  |
| XJ401230 |  | CA12 ReactorStruc - Termin Analyser House |  | 20d | 2012-08-04 | 2012-08-28 | XJ521201 FF+15d, XJ381230 |  |  |  |  | -82.5d | 0d |  | TB26 - V - Construct-Winter partly * |  |  |  | 847 |  |  | 2011-05-20 | 2012-03-10 | E-17-01-01 | XJ401230 | 2118 | 0 | 934 |  | 12 | 200 | 200 | C | LND | X | J | XJ62 | 1205 | J | 12 | X | IN | LND | 1201 | URMA |  |  |  |  |  |  |  |  |  |  |  |  |  |  |  |  |  |  |  |  |  |  | 2012-06-16 | 2011-11-01 |  |  | to be checked |  |
| XJ801201 |  | CA12 ReactorStruc - Inspections/ Mech. Acceptance/ Loop Checks |  | 80d | 2012-08-28 | 2012-11-30 | XJ641201 FS-35d, XJ401230, X3J120, X0300015, X030410030, XE601201 FS-25d, XJ391201 SS+10d, XJ701201 SS, XJ621230 FF+30d |  |  |  |  | -82.5d | 0d |  | TB26 - V - Construct-Winter partly * | Loop Checks [510 pcs]; Loop checks [2550 h] | 102,000 |  | 2550,00 |  |  | 2011-06-10 | 2012-04-30 | E-17-02-01 | XJ801201 | 2550 | 0 | 934 |  | 12 | 200 | 200 | C | LND | X | J | XJ80 | 1201 | J | 12 | X | LT | LND | 1201 | URMA |  |  |  |  |  |  |  |  |  |  |  |  |  |  |  |  |  |  |  |  |  |  | 2012-08-18 | 2012-03-01 |  |  |  | 2012-08-18 |

Notes:
- XR201201: Current Status: Relation FF change to FS after material arrival on / site

| ID | WBS | Activity | Duration | Start | Finish | Predecessors | Complete | Total float | Free float | Constraint | Calendar | Resources | Cost | Actual cost | TB26 Ressource Budget | UDF_BASELINE DEVELOPMENT | UDF_SAVE ACT ID | UDF_BUDGETED LABOR UNIT | UDF_ACTUAL LABOR UNIT | Department | Constr. Area | PMT-Area | PMT-Schedule Org | PMT-Phase | PMT-Respons. | WBS Phase | WBS Discipline | WBS Type of Work | WBS Objects | Russia WBS Discipline (Russia) | Russia Construction Area | Russia WBS Phase | IMS | UPT | Russia WBS Objects | Subcontractor | UDF_CONTRACT FINISH DATE | UDF_CONTRACT ITEM | 4 week lookahead | Civil item |
| --- | --- | --- | --- | --- | --- | --- | --- | --- | --- | --- | --- | --- | --- | --- | --- | --- | --- | --- | --- | --- | --- | --- | --- | --- | --- | --- | --- | --- | --- | --- | --- | --- | --- | --- | --- | --- | --- | --- | --- | --- |
|  | S | **Safety & Environment** |  |  |  |  |  |  |  |  |  |  |  |  |  |  |  |  |  |  |  |  |  |  |  |  |  |  |  |  |  |  |  |  |  |  |  |  |  |  |
|  | W | **Painting** |  | 2011-11-08 | 2011-12-12 |  |  |  |  |  |  |  |  |  |  |  |  |  |  |  |  |  |  |  |  |  |  |  |  |  |  |  |  |  |  |  |  |  |  |  |
| XW501201 |  | CA12 ReactorStruc - Surf.Protection Piping | 30d | 2011-11-08 | 2011-12-12 | XR201201 SS+20d, XR201201 FF, XN801201 SS+30d |  | 70d | 38d | start on or after 2011-11-01 |  | Piping painting [2129 sqm]; Piping painting [5321 h] | 3,306.68 |  | 5321,00 | SOn 1.1.11 | XW501201 | 5321 | 0 | 934 | 12 | 200 | 200 | C | LND | X | W | XW50 | 1201 | W | 12 | X | PA | LND | 1201 | VNZM |  |  |  |  |
|  | V | **Insulation** |  | 2012-02-29 | 2012-07-18 |  |  |  |  |  |  |  |  |  |  |  |  |  |  |  |  |  |  |  |  |  |  |  |  |  |  |  |  |  |  |  |  |  |  |  |
| XV301201 |  | CA12 ReactorStruc - Insulation Equipment | 100d | 2012-02-29 | 2012-07-04 | XE801201 SS+20d, XV300C00 SS |  | 32d | 0d |  | TB26 - V - Construct-Winter partly * | Equipment insulation [750 sqm]; Equipment insulation [9375 h] | 2,354.73 |  | 9375,00 |  | XV301201 | 9375 | 0 | 934 | 12 | 200 | 200 | C | LND | X | V | XV30 | 1201 | V | 12 | X | INS | LND | 1201 | VNZM | 2012-03-30 | E-13-03 |  |  |
| XV501201 |  | CA12 ReactorStruc - Insulation Piping | 100d | 2012-03-19 | 2012-07-18 | XR601201 SS+10d, XV301201 FF+12d, XE801201 FF+20d |  | 32d | 114.5d |  | TB26 - V - Construct-Winter partly * | Piping insulation [1900 sqm]; Piping insulation [14250 h] | 9,418.94 |  | 14250,00 |  | XV501201 | 14250 | 0 | 934 | 12 | 200 | 200 | C | LND | X | V | XV50 | 1201 | V | 12 | X | INS | LND | 1201 | VNZM | 2012-04-30 | E-13-01 |  |  |
|  | 02 | **CA12 - Teal Bldg Steel Structure** |  |  |  |  |  |  |  |  |  |  |  |  |  |  |  |  |  |  |  |  |  |  |  |  |  |  |  |  |  |  |  |  |  |  |  |  |  |  |
|  | C | **Civil Work** |  |  |  |  |  |  |  |  |  |  |  |  |  |  |  |  |  |  |  |  |  |  |  |  |  |  |  |  |  |  |  |  |  |  |  |  |  |  |
|  | N | **Structural Steel** |  |  |  |  |  |  |  |  |  |  |  |  |  |  |  |  |  |  |  |  |  |  |  |  |  |  |  |  |  |  |  |  |  |  |  |  |  |  |
|  | H | **HVAC** |  |  |  |  |  |  |  |  |  |  |  |  |  |  |  |  |  |  |  |  |  |  |  |  |  |  |  |  |  |  |  |  |  |  |  |  |  |  |
|  | U | **Package Units** |  |  |  |  |  |  |  |  |  |  |  |  |  |  |  |  |  |  |  |  |  |  |  |  |  |  |  |  |  |  |  |  |  |  |  |  |  |  |
|  | B | **Mechanical - Stationary Equipment** |  |  |  |  |  |  |  |  |  |  |  |  |  |  |  |  |  |  |  |  |  |  |  |  |  |  |  |  |  |  |  |  |  |  |  |  |  |  |
|  | M | **Mechanical - Rotating Equipment** |  |  |  |  |  |  |  |  |  |  |  |  |  |  |  |  |  |  |  |  |  |  |  |  |  |  |  |  |  |  |  |  |  |  |  |  |  |  |
|  | R | **Piping** |  |  |  |  |  |  |  |  |  |  |  |  |  |  |  |  |  |  |  |  |  |  |  |  |  |  |  |  |  |  |  |  |  |  |  |  |  |  |
|  | E | **Electrical** |  |  |  |  |  |  |  |  |  |  |  |  |  |  |  |  |  |  |  |  |  |  |  |  |  |  |  |  |  |  |  |  |  |  |  |  |  |  |
|  | J | **Instrumentation** |  |  |  |  |  |  |  |  |  |  |  |  |  |  |  |  |  |  |  |  |  |  |  |  |  |  |  |  |  |  |  |  |  |  |  |  |  |  |
|  | S | **Safety & Environment** |  |  |  |  |  |  |  |  |  |  |  |  |  |  |  |  |  |  |  |  |  |  |  |  |  |  |  |  |  |  |  |  |  |  |  |  |  |  |
|  | W | **Painting** |  |  |  |  |  |  |  |  |  |  |  |  |  |  |  |  |  |  |  |  |  |  |  |  |  |  |  |  |  |  |  |  |  |  |  |  |  |  |
|  | V | **Insulation** |  |  |  |  |  |  |  |  |  |  |  |  |  |  |  |  |  |  |  |  |  |  |  |  |  |  |  |  |  |  |  |  |  |  |  |  |  |  |
|  | 03 | **CA12 - Connection Structure to Extruder Bldg.** |  |  |  |  |  |  |  |  |  |  |  |  |  |  |  |  |  |  |  |  |  |  |  |  |  |  |  |  |  |  |  |  |  |  |  |  |  |  |
|  | C | **Civil Work** |  |  |  |  |  |  |  |  |  |  |  |  |  |  |  |  |  |  |  |  |  |  |  |  |  |  |  |  |  |  |  |  |  |  |  |  |  |  |
|  | N | **Structural Steel** |  |  |  |  |  |  |  |  |  |  |  |  |  |  |  |  |  |  |  |  |  |  |  |  |  |  |  |  |  |  |  |  |  |  |  |  |  |  |
|  | H | **HVAC** |  |  |  |  |  |  |  |  |  |  |  |  |  |  |  |  |  |  |  |  |  |  |  |  |  |  |  |  |  |  |  |  |  |  |  |  |  |  |
|  | U | **Package Units** |  |  |  |  |  |  |  |  |  |  |  |  |  |  |  |  |  |  |  |  |  |  |  |  |  |  |  |  |  |  |  |  |  |  |  |  |  |  |
|  | B | **Mechanical - Stationary Equipment** |  |  |  |  |  |  |  |  |  |  |  |  |  |  |  |  |  |  |  |  |  |  |  |  |  |  |  |  |  |  |  |  |  |  |  |  |  |  |
|  | M | **Mechanical - Rotating Equipment** |  |  |  |  |  |  |  |  |  |  |  |  |  |  |  |  |  |  |  |  |  |  |  |  |  |  |  |  |  |  |  |  |  |  |  |  |  |  |
|  | R | **Piping** |  |  |  |  |  |  |  |  |  |  |  |  |  |  |  |  |  |  |  |  |  |  |  |  |  |  |  |  |  |  |  |  |  |  |  |  |  |  |
|  | E | **Electrical** |  |  |  |  |  |  |  |  |  |  |  |  |  |  |  |  |  |  |  |  |  |  |  |  |  |  |  |  |  |  |  |  |  |  |  |  |  |  |
|  | J | **Instrumentation** |  |  |  |  |  |  |  |  |  |  |  |  |  |  |  |  |  |  |  |  |  |  |  |  |  |  |  |  |  |  |  |  |  |  |  |  |  |  |
|  | S | **Safety & Environment** |  |  |  |  |  |  |  |  |  |  |  |  |  |  |  |  |  |  |  |  |  |  |  |  |  |  |  |  |  |  |  |  |  |  |  |  |  |  |
|  | W | **Painting** |  |  |  |  |  |  |  |  |  |  |  |  |  |  |  |  |  |  |  |  |  |  |  |  |  |  |  |  |  |  |  |  |  |  |  |  |  |  |
|  | V | **Insulation** |  |  |  |  |  |  |  |  |  |  |  |  |  |  |  |  |  |  |  |  |  |  |  |  |  |  |  |  |  |  |  |  |  |  |  |  |  |  |
|  | 04 | **CA12 - Connection Structure Reactor to Teal Bldg** |  | 2010-07-30 | 2012-08-20 |  |  |  |  |  |  |  |  |  |  |  |  |  |  |  |  |  |  |  |  |  |  |  |  |  |  |  |  |  |  |  |  |  |  |  |
|  | C | **Civil Work** |  | 2010-07-30 | 2011-02-17 |  |  |  |  |  |  |  |  |  |  |  |  |  |  |  |  |  |  |  |  |  |  |  |  |  |  |  |  |  |  |  |  |  |  |  |
| XC20120410 |  | CA12 TealStr SK1204 - Concrete Works Foundation | 52d | 2010-07-30 A | 2010-09-28 A | XC151200, XC20120105 FS+5d, EC28120410 (other project) FS+10d, EC45120405 (other project) | 100% |  |  |  | TB26 - V - Construct-Winter partly * | Concrete works [170 cbm]; Concrete works [5100 h] | 2,771.58 |  | 5100,00 |  | XC20120410 | 5100 | 5100 | 934 | 12 | 200 | 200 | C | MO03 | X | C | XC20 | 1204 | C | 12 | X | mis | LND | 1204 | MO11 |  |  |  |  |
| XC20120405 |  | CA12 TealStr SK1204 - Precast Concrete Elements | 87d | 2010-10-30 A | 2011-02-17 A | EC28120406 (other project) FS+5d, P3C02D2 (other project) | 100% |  |  |  |  |  |  |  |  |  | XC20120405 | 0 | 0 | 934 | 12 | 200 | 200 | C | MO04 | X | C | XC40 | 1204 | C | 12 | X | pre | LND | 1204 | MO11 |  |  | x |  |
| XC20120415 |  | CA12 TealStr SK1204 - Erection Precast Elements | 10d | 2011-01-26 A | 2011-02-16 A | XC20120405 SS+30d, XC20120410 FS+10d, XC20120405 FS-20d | 100% |  |  |  | TB26 - V - Construct-Winter partly * | Precast Concrete Works [70 cbm]; Precast concrete works [175 h] | 7,000 | 7,000 | 175,00 |  | XC20120415 | 175 | 175 | 934 | 12 | 200 | 200 | C | MO04 | X | C | XC40 | 1204 | C | 12 | X | OB | LND | 1204 | MO11 |  |  | x | Comp |

Notes:
- XW501201: P3 Activity Log Info: Clarification Surface Protection during / Prefab / Current Status: 27.01.2011 (O. Siegel): die Dauer wurde von 80 auf 30 Tage / gekьrzt. Aussage von M. Siegel
- XC20120405: Current Status: 13.01.2011 (Oxana): laut Aussage von Mostostroy ca. 60% / der Arbeiten abgeschlossen. Enddatum auf den 17.01.2011 / verschoben.
- XC20120415: Current Status: 13.01.2011 (Oxana): Starttermin wurde auf den 17.01.2011 verschoben (da laut / CPMR kein Progress). Die Dauer wurde nicht geдndert.(mit Lag und Дnderung der / Verlinkung von SS auf FS). Endtermin wird laut Aussage von Mostostroy gehalten / (16-Feb-2011).

| ID | WBS | Activity | Type | Duration | Start | Finish | Predecessors | Complete | Remaining | Planned start | Planned finish | Total float | Free float | Constraint | Calendar | Resources | Cost | Actual cost | TB26 Ressource Budget | Comments | UDF_SAVE ACT ID | UDF_CHECK BASELINE | UDF_BUDGETED LABOR UNIT | UDF_ACTUAL LABOR UNIT | Department | Type of Work | Constr. Area | PMT-Area | PMT-Schedule Org | PMT-Phase | PMT-Respons. | Zeigen/n. Zeigen | WBS Phase | WBS Discipline | WBS Type of Work | WBS Objects | Russia WBS Discipline (Russia) | Russia Construction Area | Russia WBS Phase | IMS | UPT | Russia WBS Objects | UDF_CONTRACT START DATE | UDF_CONTRACT FINISH DATE | UDF_CONTRACT ITEM | TB26 Semantics | Subcontractor | UDF_CONTRACT INDICATOR | UDF_SELECT UPDATE PROGRESS | UDF_CHECK RESOURCE DATES | 4 week lookahead | UDF_PLANNED START | UDF_PLANNED FINISH | UDF_CONTRACT FINISH DATE REV1 | UDF_CONTRACT START DATE REV1 | TB26 Material Res Values | UDF_ELECTRICAL START | UDF_ELECTRICAL FINISH | UDF_Vendor Representatives |
| --- | --- | --- | --- | --- | --- | --- | --- | --- | --- | --- | --- | --- | --- | --- | --- | --- | --- | --- | --- | --- | --- | --- | --- | --- | --- | --- | --- | --- | --- | --- | --- | --- | --- | --- | --- | --- | --- | --- | --- | --- | --- | --- | --- | --- | --- | --- | --- | --- | --- | --- | --- | --- | --- | --- | --- | --- | --- | --- | --- |
|  | N | **Structural Steel** |  |  | 2011-02-22 | 2011-08-27 |  |  |  |  |  |  |  |  |  |  |  |  |  |  |  |  |  |  |  |  |  |  |  |  |  |  |  |  |  |  |  |  |  |  |  |  |  |  |  |  |  |  |  |  |  |  |  |  |  |  |  |  |  |
| XN701204 |  | CA12 TealStr SK1204 - KMD Assy Drawings | milestone | 0d | 2011-02-22 A | 2011-02-22 A |  | 100% |  |  |  |  |  | finish on 2011-02-22 | TB26 - V - Construct-Winter partly * |  |  |  | 22t | to be confirmed | XN701204 | x | 0 | 0 | 934 | XNK | 12 | 200 | 200 | C | LND | KMD | X | N | XN05 | 1204 | N | 12 | X | SS | LND | 1204 |  |  |  |  |  |  |  |  |  |  |  |  |  |  |  |  |  |
| XN711204 |  | CA12 TealStr SK1204 - Steel Deliveries | milestone | 0d | 2011-03-01 A | 2011-03-01 A |  | 100% |  |  |  |  |  | finish on 2011-02-28 | TB26 - 3 - Construction Normal 7days * CA17 |  |  |  | 22t |  | XN711204 |  | 0 | 0 | 934 | XNK | 12 | 200 | 200 | C | LND | SD | X | N | XN06 | 1204 | N | 12 | X | SS | LND | 1204 |  |  |  |  |  |  |  |  |  |  |  |  |  |  |  |  |  |
| XN201204 |  | CA12 TealStr SK1204 - Erection Primary Steel |  | 20d | 2011-08-01 A | 2011-08-23 A | P3N012D (other project) FS+10d, XN711204 FS+10d, XC401222, XN701204, P3N02EN (other project), P3N012D (other project) FF+10d, XC20120415 SS+20d | 100% |  |  |  |  |  |  | TB26 - V - Construct-Winter partly * | Piperacks, Main Structures [60 t]; Piperacks, Main structures [2550 h] | 1,773.81 |  | 2550,00 |  | XN201204 |  | 2550 | 0 | 934 | XNK | 12 | 200 | 200 | C | LND |  | X | N | XN20 | 1204 | N | 12 | X | SS | LND | 1204 | 2011-01-20 | 2011-02-28 | E-04-03 | t | ChSK |  |  |  |  |  |  |  |  |  |  |  |  |
| XN401204 |  | CA12 TealStr SK1204 - Install Railing, Ladders |  | 20d | 2011-08-24 A | 2011-08-27 A | XN201204 | 100% |  | 2011-08-24 | 2011-09-15 |  |  |  | TB26 - V - Construct-Winter partly * | Ladders & platforms [1 t]; Ladders & platforms [100 h] | 51.74 |  | 100,00 |  | XN401204 |  | 100 | 0 | 934 | XNK | 12 | 200 | 200 | C | LND |  | X | N | XN40 | 1204 | N | 12 | X | SS | LND | 1204 |  |  |  |  | ChSK |  |  |  |  |  |  |  |  |  |  |  |  |
| XN601204 |  | CA12 TealStr SK1204 - Install Gratings |  | 30d | 2011-08-24 A | 2011-08-27 A | XN401204 SS, PN691204 (other project) | 100% |  | 2011-08-24 | 2011-09-27 |  |  |  | TB26 - V - Construct-Winter partly * | Grating [150 sqm]; Grating [562.5 h] | 3,621.53 |  | 562,50 |  | XN601204 |  | 562,5 | 0 | 934 | XNK | 12 | 200 | 200 | C | LND |  | X | N | XN60 | 1204 | N | 12 | X | SS | LND | 1204 |  |  |  |  | ChSK |  |  |  |  |  |  |  |  |  |  |  |  |
|  | H | **HVAC** |  |  |  |  |  |  |  |  |  |  |  |  |  |  |  |  |  |  |  |  |  |  |  |  |  |  |  |  |  |  |  |  |  |  |  |  |  |  |  |  |  |  |  |  |  |  |  |  |  |  |  |  |  |  |  |  |  |
|  | U | **Package Units** |  |  |  |  |  |  |  |  |  |  |  |  |  |  |  |  |  |  |  |  |  |  |  |  |  |  |  |  |  |  |  |  |  |  |  |  |  |  |  |  |  |  |  |  |  |  |  |  |  |  |  |  |  |  |  |  |  |
|  | B | **Mechanical - Stationary Equipment** |  |  |  |  |  |  |  |  |  |  |  |  |  |  |  |  |  |  |  |  |  |  |  |  |  |  |  |  |  |  |  |  |  |  |  |  |  |  |  |  |  |  |  |  |  |  |  |  |  |  |  |  |  |  |  |  |  |
|  | M | **Mechanical - Rotating Equipment** |  |  |  |  |  |  |  |  |  |  |  |  |  |  |  |  |  |  |  |  |  |  |  |  |  |  |  |  |  |  |  |  |  |  |  |  |  |  |  |  |  |  |  |  |  |  |  |  |  |  |  |  |  |  |  |  |  |
|  | R | **Piping** |  |  | 2011-07-22 | 2012-03-19 |  |  |  |  |  |  |  |  |  |  |  |  |  |  |  |  |  |  |  |  |  |  |  |  |  |  |  |  |  |  |  |  |  |  |  |  |  |  |  |  |  |  |  |  |  |  |  |  |  |  |  |  |  |
| XR201204 |  | CA12 TealStr SK1204 - Piping Prefabrication |  | 66d | 2011-07-22 A | 2011-10-06 | XR200C00, ER491204 (other project) SS+18d |  | 35d |  |  | 69d | 449.5d |  |  | A/G piping prefabrication [3500 Fpi]; A/G Piping (Prefab) [13125 h] | 12,741.88 |  | 13125,00 |  | XR201204 |  | 13125 | 0 | 934 |  | 12 | 200 | 200 | C | LND |  | X | R | XR20 | 1204 | R | 12 | X | PRP | LND | 1204 |  |  |  |  | VNZM | UDF_G4 | 27.8. | planned finish ?? | x |  |  |  |  |  |  |  |  |
| XR401204 |  | CA12 TealStr SK1204 - Piping Installation |  | 60d | 2011-10-06 | 2012-01-24 | XR201204 SS+40d, P3J02AS (other project), P3J02DS (other project), P3S01S (other project), XN201204 SS, P3J04CS1 (other project), P3J04IS (other project), XR401201 SS+30d |  |  |  |  | 37d | 0d |  | TB26 - V - Construct-Winter partly * | A/G piping field installation [4280 Fpi]; A/G Piping (Field) [26750 h] | 45,306.09 |  | 26750,00 |  | XR401204 |  | 26750 | 0 | 934 |  | 12 | 200 | 200 | C | LND |  | X | R | XR40 | 1204 | R | 12 | X | PI | LND | 1204 | 2011-01-10 |  | E-06-03-03 |  | VNZM |  |  |  |  | 2011-05-20 |  |  |  |  |  |  |  |
| XR601204 |  | CA12 TealStr SK1204 - Piping Pressure Tests |  | 40d | 2011-10-08 | 2012-03-02 | XR401204 FF+18d |  |  |  |  | 74d | 0d |  | TB26 - T - Construct-Winter-3 (Dec/Jan/Feb free) * |  |  |  | 938 |  | XR601204 |  | 0 | 0 | 934 |  | 12 | 200 | 200 | C | LND |  | X | R | XR60 | 1204 | R | 12 | X | HY | LND | 1204 |  |  | E-06-03-03 |  | VNZM |  |  |  |  |  |  |  |  |  |  |  |  |
| XR801204 |  | CA12 TealStr SK1204 - Piping Reinstatement |  | 30d | 2012-01-23 | 2012-03-19 | XR601204 FF+10d, IMS-C-000360 FF |  |  |  |  | 316.5d |  |  | TB26 - V - Construct-Winter partly * |  |  |  | 469 |  | XR801204 |  | 0 | 0 | 934 |  | 12 | 200 | 200 | C | LND |  | X | R | XR80 | 1204 | R | 12 | X | PI | LND | 1204 |  | 2011-10-30 | E-06-03-03 |  | VNZM |  |  |  |  |  | 2012-03-14 |  |  |  |  |  |  |
|  | E | **Electrical** |  |  | 2010-07-30 | 2012-08-20 |  |  |  |  |  |  |  |  |  |  |  |  |  |  |  |  |  |  |  |  |  |  |  |  |  |  |  |  |  |  |  |  |  |  |  |  |  |  |  |  |  |  |  |  |  |  |  |  |  |  |  |  |  |
| XC911204 |  | CA12 TealStr SK1204 - Install Earthing&LightnSys_CIVIL |  | 62d | 2010-07-30 A | 2010-10-09 A | XC20120410 FF+10d, EE901204 (other project) | 100% |  |  |  |  |  |  | TB26 - V - Construct-Winter partly * | Grounding & Lightning [100 pcs]; Grounding & Lightning [1125 h] | 45,000 | 45,000 | 1125,00 |  | XC911204 |  | 1125 | 1125 | 934 |  | 12 | 200 | 200 | C | LND |  | X | C | XE91 | 1204 | C | 12 | X | EA | LND | 1204 |  |  |  |  | MO11 |  |  |  |  |  |  |  |  |  |  |  |  |
| XE911206 |  | CA12 TealStr SK1204 - Install Earthing&LightnSys_E/I |  | 20d | 2011-09-10 | 2011-10-03 | XN201204 FS+15d |  |  |  |  | 174d | 236.5d |  | TB26 - V - Construct-Winter partly * |  |  |  | 115 |  | XE911206 |  | 0 | 0 | 934 |  | 12 | 200 | 200 | C | LND |  | X | E | XE91 | 1204 | E | 12 | X | EA | LND | 1204 | 2011-05-10 | 2011-12-10 | E-16-07-03 |  | URMA |  |  |  |  |  |  | 2012-05-10 | 2011-07-11 |  |  |  |  |
| XE401204 |  | CA12 TealStr SK1204 - Install Cable Trays |  | 25d | 2011-11-15 | 2012-01-11 | EE46510120 (other project) FF, XN201204, EE46120410 (other project), XR401204 SS+30d |  |  |  |  | 37d | 5d |  | TB26 - V - Construct-Winter partly * | Cable trays/conduits [310 m]; Cable trays [930 h] | 37,200 |  | 930,00 |  | XE401204 | x | 930 | 0 | 934 |  | 12 | 200 | 200 | C | LND |  | X | E | XE40 | 1204 | E | 12 | X | EL | LND | 1204 | 2011-05-10 | 2011-08-20 | E-15-01-09 | m | URMA | UDF_G3 |  |  |  |  |  | 2011-12-20 | 2011-07-20 | 510 | 2011-06-04 | 2011-08-02 |  |
| XE801204 |  | CA12 TealStr SK1204 - Install Heat Tracing |  | 60d | 2011-11-29 | 2012-04-02 | XE800C00 SS, XR401204 FF+20d, E3E1950 (other project), XW501204 FF+20d, P3E19S (other project), XR601204 FF+20d |  |  |  |  | 74d | 18d |  | TB26 - V - Construct-Winter partly * | Electrical Heat Tracing [1000 m]; Electrical heat tracing [500 h] | 20,000 |  | 500,00 |  | XE801204 |  | 500 | 0 | 934 |  | 12 | 200 | 200 | C | LND |  | X | E | XE80 | 1204 | E | 12 | X | HT | LND | 1204 | 2011-06-20 | 2012-03-20 | E-16-04-01 |  | URMA | UDF_G3 |  |  |  |  |  | 2012-06-30 | 2011-09-15 |  |  |  | 005 |
| XE501204 |  | CA12 TealStr SK1204 - Cable Pulling Electric |  | 60d | 2012-06-09 | 2012-08-20 | P3E15BS (other project), XE401204, XE505102 SS+10d, XE500C01, P3E15AS (other project), EE561204 (other project), P3E15CS (other project), XE501201 SS, XE505401 SS+12d |  |  |  |  | -62.5d | 0d |  | TB26 - V - Construct-Winter partly * | Cable Pulling [5300 m]; Cable pulling [2650 h] | 106,000 |  | 2650,00 |  | XE501204 |  | 2650 | 0 | 934 |  | 12 | 200 | 200 | C | LND |  | X | E | XE50 | 1204 | E | 12 | X | EL | LND | 1204 | 2011-05-20 | 2012-02-10 | E-16-01-01 | m | URMA | UDF_G3 |  |  |  |  |  | 2012-07-01 | 2011-10-01 | 5500 | 2011-07-30 | 2011-10-07 |  |
|  | J | **Instrumentation** |  |  | 2011-11-15 | 2012-07-30 |  |  |  |  |  |  |  |  |  |  |  |  |  |  |  |  |  |  |  |  |  |  |  |  |  |  |  |  |  |  |  |  |  |  |  |  |  |  |  |  |  |  |  |  |  |  |  |  |  |  |  |  |  |
| XJ421204 |  | CA12 TealStr SK1204 - Install Secondary CableTrays |  | 30d | 2011-11-15 | 2012-01-24 | XE401204 FF, EJ46120410 (other project), XR401204 SS+30d |  |  |  |  | 62d | 86.5d |  | TB26 - V - Construct-Winter partly * | Secondary cable trays [240 m]; Install secondary cable trays [900 h] | 36,000 |  | 900,00 |  | XJ421204 | x | 900 | 0 | 934 |  | 12 | 200 | 200 | C | LND |  | X | J | XJ42 | 1204 | J | 12 | X | IN | LND | 1204 | 2011-05-10 | 2011-08-20 | E-15-01-09 | m | URMA |  |  |  |  |  |  | 2011-12-20 | 2011-07-20 | 450 | 2011-06-04 | 2011-08-02 |  |
| XJ521204 |  | CA12 TealStr SK1204 - Pulling Instrument Cables |  | 50d | 2012-05-31 | 2012-07-30 | XJ421204, XJ525102 SS+10d, XE500C01, XE401204, XJ521201 SS, XJ525401 SS+12d |  |  |  |  | -24.5d | 0d |  | TB26 - V - Construct-Winter partly * | Multicore cables [4800 m]; Pull multicore cables [2400 h] | 96,000 |  | 2400,00 |  | XJ521204 |  | 2400 | 0 | 934 |  | 12 | 200 | 200 | C | LND |  | X | J | XJ52 | 1204 | J | 12 | X | IN | LND | 1204 | 2011-05-10 | 2012-03-01 | E-17-04-03 | m | URMA |  |  |  |  |  |  | 2012-08-15 | 2011-07-25 | 3500 | 2011-08-13 | 2011-10-10 |  |

Notes:
- XN711204: Scope: 09.02.2011: weight: 65 ton - Jan 21 / ton; Feb 44 ton
- XN201204: Current Status: 14.05.2011 (O.Siegel): zur Zeit / wurden 62 t geliefert (soll 64 t).
- XE401204: Current Status: 20110705 (O.Siegel): keine / Abhдngigkeit von Piping, da die Betonfeuerschutzplaten

| ID | WBS | Activity | Type | Duration | Start | Finish | Predecessors | Complete | Remaining | Planned start | Planned finish | Total float | Free float | Constraint | Calendar | Resources | Cost | Actual cost | TB26 Ressource Budget | UDF_SELECT UPDATE PROGRESS | UDF_SAVE ACT ID | UDF_BUDGETED LABOR UNIT | UDF_ACTUAL LABOR UNIT | UDF_CHECK RESOURCE DATES | Department | Constr. Area | PMT-Area | PMT-Schedule Org | PMT-Phase | PMT-Respons. | WBS Phase | WBS Discipline | WBS Type of Work | WBS Objects | Russia WBS Discipline (Russia) | Russia Construction Area | Russia WBS Phase | IMS | UPT | Russia WBS Objects | Subcontractor | UDF_CONTRACT FINISH DATE | UDF_CONTRACT ITEM | Civil item | Comments | UDF_CHECK BASELINE | Type of Work | Zeigen/n. Zeigen | UDF_CONTRACT START DATE | TB26 Semantics | TB26 Material Res Values | 4 week lookahead | UDF_CONTRACT FINISH DATE REV1 | UDF_CONTRACT START DATE REV1 | UDF_COMMENTS_0827 | UDF_CONTRACT INDICATOR | Filter | UDF_CHECK CRITICAL PATH | UDF_EXPECTED START | UDF_EXPECTED FINISH | UDF_Concrete | UDF_SELECT |
| --- | --- | --- | --- | --- | --- | --- | --- | --- | --- | --- | --- | --- | --- | --- | --- | --- | --- | --- | --- | --- | --- | --- | --- | --- | --- | --- | --- | --- | --- | --- | --- | --- | --- | --- | --- | --- | --- | --- | --- | --- | --- | --- | --- | --- | --- | --- | --- | --- | --- | --- | --- | --- | --- | --- | --- | --- | --- | --- | --- | --- | --- | --- |
|  | S | **Safety & Environment** |  |  |  |  |  |  |  |  |  |  |  |  |  |  |  |  |  |  |  |  |  |  |  |  |  |  |  |  |  |  |  |  |  |  |  |  |  |  |  |  |  |  |  |  |  |  |  |  |  |  |  |  |  |  |  |  |  |  |  |  |
|  | W | **Painting** |  |  | 2011-08-15 | 2011-10-31 |  |  |  |  |  |  |  |  |  |  |  |  |  |  |  |  |  |  |  |  |  |  |  |  |  |  |  |  |  |  |  |  |  |  |  |  |  |  |  |  |  |  |  |  |  |  |  |  |  |  |  |  |  |  |  |  |
| XW501204 |  | CA12 TealStr SK1204 - Surf.Protection Piping |  | 67d | 2011-08-15 A | 2011-10-31 | XR201204 SS+20d |  | 56d |  |  | 177d | 103d |  |  | Piping painting [1182 sqm]; Piping painting [2954 h] | 1,837.37 |  | 2954,00 | 27.8. | XW501204 | 2954 | 0 | x | 934 | 12 | 200 | 200 | C | LND | X | W | XW50 | 1204 | W | 12 | X | PA | LND | 1204 | VNZM |  |  |  |  |  |  |  |  |  |  |  |  |  |  |  |  |  |  |  |  |  |
|  | V | **Insulation** |  |  | 2012-03-01 | 2012-05-18 |  |  |  |  |  |  |  |  |  |  |  |  |  |  |  |  |  |  |  |  |  |  |  |  |  |  |  |  |  |  |  |  |  |  |  |  |  |  |  |  |  |  |  |  |  |  |  |  |  |  |  |  |  |  |  |  |
| XV501204 |  | CA12 TealStr SK1204 - Insulation Piping |  | 60d | 2012-03-01 | 2012-05-18 | XE801204 SS+20d, XE801204 FF+20d |  |  |  |  | 83d | 165.5d |  | TB26 - T - Construct-Winter-3 (Dec/Jan/Feb free) * | Piping insulation [1100 sqm]; Piping insulation [8250 h] | 6,976.99 |  | 8250,00 |  | XV501204 | 8250 | 0 |  | 934 | 12 | 200 | 200 | C | LND | X | V | XV50 | 1204 | V | 12 | X | INS | LND | 1204 | VNZM | 2012-04-30 | E-13-01 |  |  |  |  |  |  |  |  |  |  |  |  |  |  |  |  |  |  |  |
|  | 05 | **CA12 - Agitator Removable Unit** |  |  | 2010-07-08 | 2012-04-06 |  |  |  |  |  |  |  |  |  |  |  |  |  |  |  |  |  |  |  |  |  |  |  |  |  |  |  |  |  |  |  |  |  |  |  |  |  |  |  |  |  |  |  |  |  |  |  |  |  |  |  |  |  |  |  |  |
|  | C | **Civil Work** |  |  | 2010-07-08 | 2011-12-05 |  |  |  |  |  |  |  |  |  |  |  |  |  |  |  |  |  |  |  |  |  |  |  |  |  |  |  |  |  |  |  |  |  |  |  |  |  |  |  |  |  |  |  |  |  |  |  |  |  |  |  |  |  |  |  |  |
| XC201205 |  | CA12 AgitatorRemUnit - Concrete Works Foundation |  | 300d | 2010-07-08 A | 2011-12-05 | E-21206 FS+10d, XC20120105 SS+5d, E-22206 FS+10d, EC45120505 (other project) FS+5d, EC281205 (other project) FS+5d, XN201201u FF+18d | 100% | 20d | 2010-07-08 | 2011-08-31 | 14d | 0d |  | TB26 - V - Construct-Winter partly * | Concrete works [120 cbm]; Concrete works [3600 h] |  |  | 3600,00 | 27.8. | XC201205 | 3600 | 600 | x | 934 | 12 | 200 | 200 | C | MO03 | X | C | XC20 | 1205 | C | 12 | X | mis | LND | 1205 | MO11 |  |  | x |  |  |  |  |  |  |  |  |  |  |  |  |  |  |  |  |  |  |
|  | N | **Structural Steel** |  |  | 2011-02-22 | 2012-03-07 |  |  |  |  |  |  |  |  |  |  |  |  |  |  |  |  |  |  |  |  |  |  |  |  |  |  |  |  |  |  |  |  |  |  |  |  |  |  |  |  |  |  |  |  |  |  |  |  |  |  |  |  |  |  |  |  |
| XN701205 |  | CA12 AgitatorRemUnit SK1205 - KMD Assy Drawings | milestone | 0d | 2011-02-22 A | 2011-02-22 A |  | 100% |  |  |  |  |  | finish on 2011-02-22 | TB26 - V - Construct-Winter partly * |  |  |  | 22t |  | XN701205 | 0 | 0 |  | 934 | 12 | 200 | 200 | C | LND | X | N | XN05 | 1205 | N | 12 | X | SS | LND | 1205 |  |  |  |  | to be confirmed | x | XNK | KMD |  |  |  |  |  |  |  |  |  |  |  |  |  |  |
| XN711205 |  | CA12 AgitatorRemUnit SK1205 - Steel Deliveries | milestone | 0d | 2011-03-27 A | 2011-03-27 A |  | 100% |  |  |  |  |  | finish on 2011-02-28 | TB26 - 3 - Construction Normal 7days * CA17 |  |  |  | 22t |  | XN711205 | 0 | 0 |  | 934 | 12 | 200 | 200 | C | LND | X | N | XN06 | 1205 | N | 12 | X | SS | LND | 1205 |  |  |  |  |  |  | XNK | SD |  |  |  |  |  |  |  |  |  |  |  |  |  |  |
| XN201205 |  | CA12 AgitatorRemUnit SK1205 - Erection Primary Steel |  | 20d | 2011-12-06 | 2012-01-25 | P3N02FN (other project), XB30120110, XN701205, XB30130115, XC201205, XN711205 FS+10d, XN201204 |  |  |  |  | 14d | 0d |  | TB26 - V - Construct-Winter partly * | Piperacks, Main Structures [117 t]; Piperacks, Main structures [4972.5 h] | 4,138.89 |  | 4972,50 |  | XN201205 | 4972,5 | 0 |  | 934 | 12 | 200 | 200 | C | LND | X | N | XN20 | 1205 | N | 12 | X | SS | LND | 1205 | ChSK | 2011-02-28 | E-04-04 |  |  |  | XNK |  | 2011-02-10 | t | 110 | x |  |  |  |  |  |  |  |  |  |  |
| XN401205 |  | CA12 AgitatorRemUnit SK1205 - Install Railing, Ladders |  | 10d | 2012-01-30 | 2012-02-20 | XN201205 |  |  |  |  | 14d | 0d |  | TB26 - V - Construct-Winter partly * | Ladders & platforms [8 t]; Ladders & platforms [800 h] | 362.15 |  | 800,00 |  | XN401205 | 800 | 0 |  | 934 | 12 | 200 | 200 | C | LND | X | N | XN40 | 1205 | N | 12 | X | SS | LND | 1205 | ChSK |  |  |  |  |  | XNK |  |  |  |  |  |  |  |  |  |  |  |  |  |  |  |
| XN601205 |  | CA12 AgitatorRemUnit SK1205 - Install Gratings |  | 20d | 2012-01-30 | 2012-03-07 | P691205 (other project), XN401205 SS |  |  |  |  | 14d | 0d |  | TB26 - V - Construct-Winter partly * | Grating [250 sqm]; Grating [937.5 h] | 13,451.4 |  | 937,50 |  | XN601205 | 937,5 | 0 |  | 934 | 12 | 200 | 200 | C | LND | X | N | XN60 | 1205 | N | 12 | X | SS | LND | 1205 | ChSK |  |  |  |  |  | XNK |  |  |  |  |  |  |  |  |  |  |  |  |  |  |  |
|  | H | **HVAC** |  |  |  |  |  |  |  |  |  |  |  |  |  |  |  |  |  |  |  |  |  |  |  |  |  |  |  |  |  |  |  |  |  |  |  |  |  |  |  |  |  |  |  |  |  |  |  |  |  |  |  |  |  |  |  |  |  |  |  |  |
|  | U | **Package Units** |  |  |  |  |  |  |  |  |  |  |  |  |  |  |  |  |  |  |  |  |  |  |  |  |  |  |  |  |  |  |  |  |  |  |  |  |  |  |  |  |  |  |  |  |  |  |  |  |  |  |  |  |  |  |  |  |  |  |  |  |
|  | B | **Mechanical - Stationary Equipment** |  |  |  |  |  |  |  |  |  |  |  |  |  |  |  |  |  |  |  |  |  |  |  |  |  |  |  |  |  |  |  |  |  |  |  |  |  |  |  |  |  |  |  |  |  |  |  |  |  |  |  |  |  |  |  |  |  |  |  |  |
|  | M | **Mechanical - Rotating Equipment** |  |  |  |  |  |  |  |  |  |  |  |  |  |  |  |  |  |  |  |  |  |  |  |  |  |  |  |  |  |  |  |  |  |  |  |  |  |  |  |  |  |  |  |  |  |  |  |  |  |  |  |  |  |  |  |  |  |  |  |  |
|  | R | **Piping** |  |  |  |  |  |  |  |  |  |  |  |  |  |  |  |  |  |  |  |  |  |  |  |  |  |  |  |  |  |  |  |  |  |  |  |  |  |  |  |  |  |  |  |  |  |  |  |  |  |  |  |  |  |  |  |  |  |  |  |  |
|  | E | **Electrical** |  |  |  |  |  |  |  |  |  |  |  |  |  |  |  |  |  |  |  |  |  |  |  |  |  |  |  |  |  |  |  |  |  |  |  |  |  |  |  |  |  |  |  |  |  |  |  |  |  |  |  |  |  |  |  |  |  |  |  |  |
|  | J | **Instrumentation** |  |  | 2012-03-09 | 2012-04-06 |  |  |  |  |  |  |  |  |  |  |  |  |  |  |  |  |  |  |  |  |  |  |  |  |  |  |  |  |  |  |  |  |  |  |  |  |  |  |  |  |  |  |  |  |  |  |  |  |  |  |  |  |  |  |  |  |
| XJ381230 |  | CA12 AgitatorRemUnit - Install Analyser House |  | 25d | 2012-03-09 | 2012-04-06 | P3J07S1 (other project), XN601205 |  |  |  |  | 17d | 0d |  |  |  |  |  |  |  | XJ381230 | 0 | 0 |  | 934 | 12 | 200 | 200 | C | LND | X | J | XJ38 | 1205 | J | 12 | X | IN | LND | 1205 | URMA | 2012-03-01 | E-17-04-03 |  |  |  |  |  | 2011-05-10 |  |  |  | 2012-08-15 | 2011-07-25 | to be checked |  |  |  |  |  |  |  |
|  | S | **Safety & Environment** |  |  |  |  |  |  |  |  |  |  |  |  |  |  |  |  |  |  |  |  |  |  |  |  |  |  |  |  |  |  |  |  |  |  |  |  |  |  |  |  |  |  |  |  |  |  |  |  |  |  |  |  |  |  |  |  |  |  |  |  |
|  | W | **Painting** |  |  |  |  |  |  |  |  |  |  |  |  |  |  |  |  |  |  |  |  |  |  |  |  |  |  |  |  |  |  |  |  |  |  |  |  |  |  |  |  |  |  |  |  |  |  |  |  |  |  |  |  |  |  |  |  |  |  |  |  |
|  | V | **Insulation** |  |  |  |  |  |  |  |  |  |  |  |  |  |  |  |  |  |  |  |  |  |  |  |  |  |  |  |  |  |  |  |  |  |  |  |  |  |  |  |  |  |  |  |  |  |  |  |  |  |  |  |  |  |  |  |  |  |  |  |  |
|  | 21 | **CA12 - Catalyst Building Line 1** |  |  | 2010-07-19 | 2012-11-03 |  |  |  |  |  |  |  |  |  |  |  |  |  |  |  |  |  |  |  |  |  |  |  |  |  |  |  |  |  |  |  |  |  |  |  |  |  |  |  |  |  |  |  |  |  |  |  |  |  |  |  |  |  |  |  |  |
|  | C | **Civil Work** |  |  | 2010-07-19 | 2012-05-05 |  |  |  |  |  |  |  |  |  |  |  |  |  |  |  |  |  |  |  |  |  |  |  |  |  |  |  |  |  |  |  |  |  |  |  |  |  |  |  |  |  |  |  |  |  |  |  |  |  |  |  |  |  |  |  |  |
| XC20122105 |  | CA12 Catalyst Bldg SK1206 - Concrete Works Building Fdtn +0.00 |  | 217d | 2010-07-19 A | 2011-07-30 A | XC151200, XC20120105 SS+10d, EC48122103 (other project) FS+10d | 100% |  | 2010-07-19 | 2011-06-04 |  |  |  | TB26 - V - Construct-Winter partly * | Concrete works [60 cbm]; Concrete works [1800 h] | 72,000 | 20,028.24 | 1800,00 |  | XC20122105 | 1800 | 1800 |  | 934 | 12 | 200 | 200 | C | MO03 | X | C | XC20 | 1221 | C | 12 | X | OB | LND | 1221 | MO11 |  |  |  |  |  |  |  |  |  |  |  |  |  |  |  |  |  |  |  |  |  |
| XC401221 |  | CA12 Catalyst Bldg SK1206 - Concrete Works Building |  | 322d | 2010-09-16 A | 2011-12-28 | EC48122120 (other project) FF+20d, P3C02D2 (other project), XC201221 FF, EC48122115 (other project) FF+20d, XC20120105 FS+20d, XC20122105 SS+20d, EC48122105 (other project) FS+10d, EC48122110 (other project) FF+20d |  | 86d |  |  | -47d | 0d |  | TB26 - V - Construct-Winter partly * | Concrete works [330 cbm]; Concrete works [9900 h] | 5,912.7 |  | 9900,00 | 27.8. | XC401221 | 9900 | 3000 | x | 934 | 12 | 200 | 200 | C | MO04 | X | C | XC40 | 1221 | C | 12 | X | OB | LND | 1221 | MO11 |  |  | x |  |  |  |  |  |  |  | x |  |  |  | UDF_G4 |  |  |  |  |  |  |
| XC201221 |  | CA12 Catalyst Bldg SK1206 - Concrete Works EqptFdtn |  | 20d | 2011-11-17 | 2011-12-28 | EC45122105 (other project), XC20122105, EC281221 (other project) FS+20d |  |  |  |  | -47d | 0d | as late as possible | TB26 - V - Construct-Winter partly * | Concrete works [60 cbm]; Concrete works [1800 h] | 923.86 |  | 1800,00 | 27.8. | XC201221 | 1800 | 1170 | x | 934 | 12 | 200 | 200 | C | MO04 | X | C | XC20 | 1221 | C | 12 | X | mis | LND | 1221 | MO11 |  |  | x |  |  |  |  |  |  |  |  |  |  |  | UDF_G4 | 1 |  |  |  |  |  |
| XC40122110 |  | CA12 Catalyst Bldg SK1206 - Concrete Works Building finished | milestone | 0d | 2011-12-28 | 2011-12-28 | XC401221 FF, IMS-C-000110 FF |  |  |  |  | -3d | 0d |  | TB26 - V - Construct-Winter partly * |  |  |  |  |  | XC40122110 | 0 | 0 |  | 934 | 12 | 200 | 200 | C | MO04 | X | C | XC40 | 1221 | C | 11 | X | OB | LND | 1110 | MO11 |  |  |  |  |  |  | D |  |  |  |  |  |  |  |  |  | SK1206 | 2011-06-25 | 2011-06-25 |  |  |
| XC501221 |  | CA12 Catalyst Bldg SK1206 - Finishing Works Rooms |  | 100d | 2011-12-31 | 2012-05-05 | XC401221, XC911221 FF+20d, XN801221 FF+20d, XC40122110, XC001221 FF, XC510C00 FS+15d, EC501221 (other project) |  |  |  |  | 28d | 0d |  |  | Finishing Works - Catalyst Buildings CA12/13 [31282 mhr]; Finishing Works - Catalyst buildings [31281 h] | 3,128,200 |  | 31282,00 |  | XC501221 | 31281 | 0 |  | 934 | 12 | 200 | 200 | C | CiC | X | C | XC50 | 1221 | C | 12 | X | OB | LND | 1221 |  |  |  |  |  |  |  |  |  |  |  |  |  |  |  |  | x | SK1206 |  |  | 1 | XC50 |
| XC501221_1 |  | CA12 Catalyst Bldg SK1206 - Plastering and Painting (Finishing Works) |  | 25d | 2011-12-31 | 2012-02-04 | XC501221 SS |  |  |  |  | 28d | 0d |  |  |  |  |  | 31282,00 |  | XC501221 | 31281 | 0 |  | 934 | 12 | 200 | 200 | C | CiC | X | C | XC50 | 1221 | C | 12 | X | OB | LND | 1221 |  |  |  |  |  |  |  |  |  |  |  |  |  |  |  |  | x | SK1206 |  |  | 1 |  |

Notes:
- XW501204: P3 Activity Log Info: Clarification Surface Protection during Prefab
- XC201205: Current Status: 20110801 (O.Siegel): die Fundamente / kцnnen gemacht werden, erst wenn CA1201 fertig ist und Excavation abgeschlossen / ist. die geplante Dauer bis zur Fertigstellung wird dann 3 Wochen betragen.
- XN711205: Current Status: 12.04.2011 (O.Siegel): 94,67% geliefert
- XN201205: Current Status: 20110601 (O.Siegel): die Fundamente / kцnnen erst nach dem der Mamoet-Kran weg ist, abgeschlossen werden.
- XJ381230: Current Status: 13.04.2011 (O.Siegel): Liefertermin noch unklar. erst wenn / dieser sicher ist, wird diese UNIT Fa. URMA als Aufgabenfeld / gezeigt.
- XC401221: Current Status: 110801 (O.Siegel): nach Rьcksprache mit Goran R. wurde / das Fertigstellungsdatum um eine Woche (vom 05.09.2011 auf den 12.09.2011) / verschoben. / 110303 (WL) Resume Date 11.04.11 nach Vorgabe H. Bucher / 110502 (O. Siegel): dem Wunsch von MO11, die Arbeiten erst am Mitte / April bis Mitte Mai durchzufьhren kann nicht entsprochen werden. MO11 muss die / Arbeiten Ende Mдrz wieder aufnehmen und Mitte April Baufreiheit fьr Steel / Structure gewдhrleisten / 110112 (O.Siegel): eine Unterbrechung zw. 01.12.2010 und 11.01.2011 / eingebaut (Keine Zuordnung des kalenders, sondern eine Unterbrechung). / Enddatum 01.03.2011 (nach Abstimmung mit Mostostroy am 11.01.2011). / Corrective Actions: 05.02.2011 (O. Siegel). die Ressourcen von Concrete Works / EqptFdtn drauf addiert, damit die Ressourcen-Curve ьbereinstimmt mit dem / CPMR
- XC40122110: P3 Activity Log Info: excl. openings for / Compressor Lifts
- XC501221: Current Status: 13.01.11 Volkmann- Finishing Works in Warmperiode in / Absprache mit MO11 verschoben mit weichem Constrain.
- XC501221_1: Current Status: 13.01.11 Volkmann- Finishing Works in Warmperiode in / Absprache mit MO11 verschoben mit weichem Constrain.

| ID | WBS | Activity | Type | Duration | Start | Finish | Predecessors | Complete | Total float | Free float | Constraint | Calendar | Resources | Cost | TB26 Ressource Budget | Comments | UDF_SAVE ACT ID | UDF_CHECK BASELINE | UDF_BUDGETED LABOR UNIT | UDF_ACTUAL LABOR UNIT | Department | Type of Work | Constr. Area | PMT-Area | PMT-Schedule Org | PMT-Phase | PMT-Respons. | Zeigen/n. Zeigen | WBS Phase | WBS Discipline | WBS Type of Work | WBS Objects | Russia WBS Discipline (Russia) | Russia Construction Area | Russia WBS Phase | IMS | UPT | Russia WBS Objects | UDF_SELECT UPDATE PROGRESS | TB26 Semantics | Inquiry/Order No | Subcontractor | UDF_CHECK CRITICAL PATH | Filter | UDF_SELECT | UDF_CONTRACT START DATE | UDF_CONTRACT FINISH DATE | UDF_L3 START DATE | UDF_L3 FINISH DATE | UDF_Weight (ton) | WEIGHT | UDF_LEVEL | UDF_TAG No | UDF_Object No | UDF_PACKAGE | UDF_PO No | UDF_DELIVERY DATE PO | UDF_DELIVERY DATE DISPATCH PLANNED | UDF_DELIVERY DATE TO SITE PLANNED | UDF_DELIVERY DATE SITE NEED DATE | UDF_SUPPLIER | UDF_COMMENTS | Drawing Indicator | UDF_CONTRACT ITEM | UDF_ELECTRICAL SEQUENCE |
| --- | --- | --- | --- | --- | --- | --- | --- | --- | --- | --- | --- | --- | --- | --- | --- | --- | --- | --- | --- | --- | --- | --- | --- | --- | --- | --- | --- | --- | --- | --- | --- | --- | --- | --- | --- | --- | --- | --- | --- | --- | --- | --- | --- | --- | --- | --- | --- | --- | --- | --- | --- | --- | --- | --- | --- | --- | --- | --- | --- | --- | --- | --- | --- | --- | --- |
|  | N | **Structural Steel** |  |  | 2011-02-21 | 2012-04-11 |  |  |  |  |  |  |  |  |  |  |  |  |  |  |  |  |  |  |  |  |  |  |  |  |  |  |  |  |  |  |  |  |  |  |  |  |  |  |  |  |  |  |  |  |  |  |  |  |  |  |  |  |  |  |  |  |  |  |  |
| XN701206 |  | CA12 Catalyst Bldg SK1206 - KMD Assy Drawings | milestone | 0d | 2011-02-21 A | 2011-02-21 A |  | 100% |  |  | finish on 2011-02-21 | TB26 - V - Construct-Winter partly * |  |  | 22t | to be confirmed | XN701206 | x | 0 | 0 | 934 | XNK | 12 | 200 | 200 | C | LND | KMD | X | N | XN05 | 1221 | N | 12 | X | SS | LND | 1221 |  |  |  |  |  |  |  |  |  |  |  |  |  |  |  |  |  |  |  |  |  |  |  |  |  |  |  |
| XN711206 |  | CA12 Catalyst Bldg SK1206 - Steel Deliveries | milestone | 0d | 2011-08-02 A | 2011-08-02 A |  | 100% |  |  | finish on 2011-08-01 | TB26 - 3 - Construction Normal 7days * CA17 |  |  | 22t | 9 t from 32 t at site | XN711206 |  | 0 | 0 | 934 | XNK | 12 | 200 | 200 | C | LND | SD | X | N | XN06 | 1221 | N | 12 | X | SS | LND | 1221 | 27.8. |  |  |  |  |  |  |  |  |  |  |  |  |  |  |  |  |  |  |  |  |  |  |  |  |  |  |
| XN211206 |  | CA12 Catalyst Bldg SK1206 - Install Prim Steel / Eqpt Platforms |  | 20d | 2012-01-17 | 2012-02-29 | V-21103 SS+10d, XN701206, P3N02RN (other project), XC401221 FS-5d, XN711206 FS+10d, V-21106 SS+10d |  | -39d | 0d |  | TB26 - V - Construct-Winter partly * | Piperacks, Main Structures [32 t]; Piperacks, Main structures [1360 h] | 54,400 | 1360,00 |  | XN211206 |  | 1360 | 0 | 934 | XNK | 12 | 200 | 200 | C | LND |  | X | N | XN30 | 1221 | N | 12 | X | SS | LND | 1205 |  | t | 2DC8460 | ChSK |  |  |  |  |  |  |  |  |  |  |  |  |  |  |  |  |  |  |  |  |  |  |  |
| XN401221 |  | CA12 Catalyst Bldg SK1206 - Install Railings,Ladders,etc. |  | 25d | 2012-03-01 | 2012-04-05 | XN211206 SS+20d |  | 71d | 0d |  | TB26 - V - Construct-Winter partly * | Ladders & platforms [3 t]; Ladders & platforms [300 h] | 12,000 | 300,00 |  | XN401221 |  | 300 | 0 | 934 | XNK | 12 | 200 | 200 | C | LND |  | X | N | XN40 | 1221 | N | 12 | X | SS | LND | 1205 |  |  |  | ChSK |  |  |  |  |  |  |  |  |  |  |  |  |  |  |  |  |  |  |  |  |  |  |  |
| XN801221 |  | CA12 Catalyst Bldg SK1206 - Cladding Works Walls/Roof |  | 30d | 2012-03-01 | 2012-04-11 | XN211206 |  | -39d | 0d | start on or after 2011-10-31 | TB26 - V - Construct-Winter partly * | Cladding [800 sqm]; Cladding [4000 h] | 160,000 | 4000,00 |  | XN801221 |  | 4000 | 0 | 934 | XNK | 12 | 200 | 200 | C | LND | D | X | N | XN80 | 1221 | N | 12 | X | SS | LND | 1205 |  |  |  | ChSK | SK1206 |  |  |  |  |  |  |  |  |  |  |  |  |  |  |  |  |  |  |  |  |  |  |
| XN601221 |  | CA12 Catalyst Bldg SK1206 - Install Gratings |  | 20d | 2012-03-09 | 2012-04-05 | XN401221 FF |  | 71d | 133.5d |  | TB26 - V - Construct-Winter partly * | Grating [150 sqm]; Grating [562.5 h] | 22,500 | 562,50 |  | XN601221 |  | 562,5 | 0 | 934 | XNK | 12 | 200 | 200 | C | LND |  | X | N | XN60 | 1221 | N | 12 | X | SS | LND | 1205 |  |  |  | ChSK |  |  |  |  |  |  |  |  |  |  |  |  |  |  |  |  |  |  |  |  |  |  |  |
|  | H | **HVAC** |  |  | 2012-02-06 | 2012-07-23 |  |  |  |  |  |  |  |  |  |  |  |  |  |  |  |  |  |  |  |  |  |  |  |  |  |  |  |  |  |  |  |  |  |  |  |  |  |  |  |  |  |  |  |  |  |  |  |  |  |  |  |  |  |  |  |  |  |  |  |
| XH00122105 |  | CA12 Catalyst Bldg - Installation HVAC |  | 80d | 2012-02-06 | 2012-05-12 | EH30122105 (other project), P3H01SD (other project), XC40122110, XC501221 SS+25d, XH000000 FF, XC501221_1 |  | 28d | 0d |  |  | HVAC - Catalyst Buildings CA12/13 [9344 mhr]; HVAC - Catalyst buildings [9344 h] |  | 9343,00 |  | XH00122105 |  | 9344 | 0 | 934 |  | 12 | 200 | 200 | C | LND |  | X | H | XH00 | 1221 | H | 12 | X | hvac | LND | 1221 |  |  |  | ARMO | SK1206 | x | REL XC50 | 2011-03-05 | 2011-05-30 | 2011-05-12 | 2011-08-01 |  |  |  |  |  |  |  |  |  |  |  |  |  |  |  |  |
| XH00122110 |  | CA12 Catalyst Bldg - Testing/Commissng HVAC (Start w. temp. Power) |  | 60d | 2012-05-14 | 2012-07-23 | XH000C10, XH00122105, X0300080, X0300008 FS+20d |  | 28d | 0d |  |  |  |  |  |  | XH00122110 |  | 0 | 0 | 934 |  | 12 | 200 | 200 | C | LND |  | X | H | XH20 | 1221 | H | 12 | X | hvac | LND | 1221 |  |  |  | ARMO | SK1206 |  |  |  |  | 2011-08-01 | 2011-09-27 |  |  |  |  |  |  |  |  |  |  |  |  |  |  |  |  |
| XH00122107 |  | CA12 Catalyst Bldg - HVAC ready for Heating | milestone | 0d | 2012-05-25 | 2012-05-25 | XH00122110 SS+10d |  | 262.5d | 78.5d |  |  |  |  | 3809 |  | XH00122107 |  | 0 | 0 | 934 |  | 12 | 200 | 200 | C | LND |  | X | H | XH00 | 1221 | H | 12 | X | hvac | LND | 1221 |  |  |  | ARMO | SK1206 |  |  |  |  | 2011-08-12 | 2011-08-12 |  |  |  |  |  |  |  |  |  |  |  |  |  |  |  |  |
|  | U | **Package Units** |  |  |  |  |  |  |  |  |  |  |  |  |  |  |  |  |  |  |  |  |  |  |  |  |  |  |  |  |  |  |  |  |  |  |  |  |  |  |  |  |  |  |  |  |  |  |  |  |  |  |  |  |  |  |  |  |  |  |  |  |  |  |  |
|  | B | **Mechanical - Stationary Equipment** |  |  | 2011-12-29 | 2012-03-24 |  |  |  |  |  |  |  |  |  |  |  |  |  |  |  |  |  |  |  |  |  |  |  |  |  |  |  |  |  |  |  |  |  |  |  |  |  |  |  |  |  |  |  |  |  |  |  |  |  |  |  |  |  |  |  |  |  |  |  |
| MI-21101 |  | CATALYST DRUM ROLLER |  | 5d | 2011-12-29 | 2012-01-10 | XC40122110, XB001221 FF, XC201221, P3A03S1 (other project), XB001221 SS |  | 2d | 62d |  |  | Static equipment < 10t [30 h]; Static Equipment < 10 tons [0.3 t] | 1,200 | 30,00 |  | MI-21101 |  | 30 | 0 |  |  | 12 |  |  |  |  | EQ | X | B |  | 1221 |  |  |  |  |  |  |  |  |  | VNZM |  |  |  |  |  |  |  | 0,3 | 1500 | concrete +0.00 | MI-21101 | SK1221 | A03 CATALYST DRUM ROLLER (MI-21-/22101) |  |  |  |  |  |  |  |  |  |  |
| MI-22101 |  | CATALYST DRUM ROLLER |  | 5d | 2011-12-29 | 2012-01-10 | XB001321 FF, P3A03S2 (other project), XC201321, XB001321 SS, XC40132110 |  | -43d | 20d |  |  | Static Equipment < 10 tons [0.3 t]; Static equipment < 10t [30 h] | 1,200 | 30,00 |  | MI-22101 |  | 30 | 0 |  |  | 13 |  |  |  |  | EQ | X | B |  | 1321 |  |  |  |  |  |  |  |  |  | VNZM |  |  |  |  |  |  |  | 0,3 | 1500 | concrete +0.00 | MI-22101 | SK1321 | A03 CATALYST DRUM ROLLER (MI-21-/22101) |  |  |  |  |  |  |  |  |  |  |
| V-21103 |  | PRESSURE EQUIPMENT (Alternative Modifier Drum) |  | 10d | 2011-12-29 | 2012-01-16 | XC201221, XB001221 FF, XB001221 SS, XC401221, P3A01S1 (other project) |  | -64d | 0d |  |  | Static Equipment < 10 tons [2 t]; Static equipment < 10t [200 h] | 8,000 | 200,00 |  | V-21103 |  | 200 | 0 |  |  | 12 |  |  |  |  | EQ | X | B |  | 1221 |  |  |  |  |  |  |  |  |  | VNZM |  |  |  |  |  |  |  | 2 | 2000 | concrete +0.00 | V-21103 | SK1221 | A01 PRESSURE EQUIPMENT | 2 DD 8530 | 2010-10-02 | 2010-11-30 | 2011-02-10 | 2010-12-23 | GMM Pfaudler | installation before Steel Str. |  |  |  |
| V-21106 |  | PRESSURE EQUIPMENT (Teal Seal Drum) |  | 10d | 2011-12-29 | 2012-01-16 | XB001221 SS, P3A01S1 (other project), XC201221, XC401221, XB001221 FF |  | -64d | 0d |  |  | Static Equipment < 10 tons [2.5 t]; Static equipment < 10t [250 h] | 10,000 | 250,00 |  | V-21106 |  | 250 | 0 |  |  | 12 |  |  |  |  | EQ | X | B |  | 1221 |  |  |  |  |  |  |  |  |  | VNZM |  |  |  |  |  |  |  | 2,5 | 2500 | structure +2.50 | V-21106 | SK1221 | A01 PRESSURE EQUIPMENT | 2 DD 8530 | 2010-10-02 | 2010-11-30 | 2011-02-10 | 2010-12-23 | GMM Pfaudler | installation before Steel Str. |  |  |  |
| V-22106 |  | PRESSURE EQUIPMENT (Teal Seal Drum) |  | 10d | 2011-12-29 | 2012-01-16 | XB001321 SS, P3A01S2 (other project), XC20132105, XC201321, XB001321 FF |  | -63d | 0d |  |  | Static Equipment < 10 tons [2.7 t]; Static equipment < 10t [270 h] | 10,800 | 270,00 |  | V-22106 | x | 270 | 0 |  |  | 13 |  |  |  |  | EQ | X | B |  | 1321 |  |  |  |  |  |  |  |  |  | VNZM |  |  |  |  |  |  |  | 2,7 | 2500 | structure +2.50 | V-22106 | SK1321 | A01 PRESSURE EQUIPMENT | 2 DD 8530 | 2010-10-02 | 2010-11-30 | 2011-02-10 | 2010-12-23 | GMM Pfaudler |  |  |  |  |
| XB001221 |  | CA12 Catalyst Bldg - Install Static Eqpt | level of effort | 67d | 2011-12-29 | 2012-03-24 |  |  | -60d | 0d |  |  |  |  | 9 | E-08-01-08 | XB001221 |  | 0 | 0 | 934 | XBB | 12 | 200 | 200 | C | LND |  | X | B | XB00 | 1221 | B | 12 | X | EQ | LND | 1221 |  |  |  | VNZM | SK1206 |  |  | 2011-03-10 | 2011-05-10 |  |  |  |  |  |  |  |  |  |  |  |  |  |  |  | UDF_G2 | E-08-01-08 |  |
| V-21108 |  | PRESSURE EQUIPMENT (Mineral Oil Storage Drum) |  | 10d | 2012-02-08 | 2012-02-18 | XN211206 SS+10d, P3A01S1 (other project), XB001221 FF, V-21106, XB001221 SS, V-21103 |  | -52d | 0d |  |  | Static Equipment < 10 tons [1.5 t]; Static equipment < 10t [150 h] | 6,000 | 150,00 | Heat Tracing Insulation ET90 | V-21108 |  | 150 | 0 |  |  | 12 |  |  |  |  | EQ | X | B |  | 1221 |  |  |  |  |  |  |  |  |  | VNZM |  |  |  |  |  |  |  | 1,5 | 1500 | concrete +6.80 | V-21108 | SK1221 | A01 PRESSURE EQUIPMENT | 2 DD 8530 | 2010-10-02 | 2010-11-30 | 2011-02-10 | 2010-12-23 | GMM Pfaudler | after inst. St.Str. Level 105, and before St.Str. Level 109 |  |  |  |
| MI-22104 A/B |  | SCALES (Donor Container Weigh Scales) |  | 10d | 2012-02-09 | 2012-02-20 | P3A13S2A (other project), XC40132110, XN301321, XB001321 FF, XB001321 SS, XC201321 |  | -53d | 5d |  |  | Static Equipment < 10 tons [0.6 t]; Static equipment < 10t [60 h] | 2,400 | 60,00 |  | MI-22104 A/B | x | 60 | 0 |  |  | 13 |  |  |  |  | EQ | X | B |  | 1321 |  |  |  |  |  |  |  |  |  | VNZM |  |  |  |  |  |  |  | 0,6 | 1500 | concrete +0.00 | MI-22104 A/B | SK1321 | A13 SCALES (MI-21-/22104/6A/B) |  |  |  |  |  |  |  |  |  |  |
| AG-22101 |  | PRESSURE EQUIPMENT (Catalyst Hold Drum Agitator) |  | 5d | 2012-02-21 | 2012-02-27 | V-22101, XB001321 FF, P3A01S2 (other project), XB001321 SS |  | -58d | 0d |  |  | Static Equipment < 10 tons [0.25 t]; Static equipment < 10t [25 h] | 1,000 | 25,00 |  | AG-22101 |  | 25 | 0 |  |  | 13 |  |  |  |  | EQ | X | B |  | 1321 |  |  |  |  |  |  |  |  |  | VNZM |  |  |  |  |  |  |  | 0,25 | 2000 | concrete +0.00 | AG-22101 | SK1321 | A01 PRESSURE EQUIPMENT | 2 DD 8530 | 2010-10-02 | 2010-11-30 | 2011-02-10 | 2010-12-23 | GMM Pfaudler |  |  |  | XJ321321 |
| MI-21104 A/B |  | SCALES (Donor Container Weigh Scales) |  | 10d | 2012-03-01 | 2012-03-13 | P3A13S1A (other project), XC40122110, XB001221 FF, XB001221 SS, XN211206, XC201221 |  | -50d | 10d |  |  | Static Equipment < 10 tons [0.6 t]; Static equipment < 10t [60 h] | 2,400 | 60,00 |  | MI-21104 A/B |  | 60 | 0 |  |  | 12 |  |  |  |  | EQ | X | B |  | 1221 |  |  |  |  |  |  |  |  |  | VNZM |  |  |  |  |  |  |  | 0,6 | 1500 | concrete +0.00 | MI-21104 A/B | SK1221 | A13 SCALES (MI-21-/22104/6A/B) |  |  |  |  |  |  |  |  |  |  |
| V-21101 |  | PRESSURE EQUIPMENT (Catalyst Hold Drum) |  | 10d | 2012-03-01 | 2012-03-13 | XB001221 FF, V-21103, XN211206 SS+20d, XB001221 SS, V-21106, V-21108, P3A01S1 (other project) |  | -60d | 0d |  |  | Static Equipment < 10 tons [0.8 t]; Static equipment < 10t [80 h] | 3,200 | 80,00 |  | V-21101 |  | 80 | 0 |  |  | 12 |  |  |  |  | EQ | X | B |  | 1221 |  |  |  |  |  |  |  |  |  | VNZM |  |  |  |  |  |  |  | 0,8 | 800 | structure +10.85 | V-21101 | SK1221 | A01 PRESSURE EQUIPMENT | 2 DD 8530 | 2010-10-02 | 2010-11-30 | 2011-02-10 | 2010-12-23 | GMM Pfaudler | inst. before St.Str. Level 114 |  |  |  |
| AG-21101 |  | PRESSURE EQUIPMENT (Catalyst Hold Drum Agitator) |  | 5d | 2012-03-14 | 2012-03-19 | XB001221 SS, XB001221 FF, V-21101, P3A01S1 (other project) |  | -60d | 0d |  |  | Static Equipment < 10 tons [0.25 t]; Static equipment < 10t [25 h] | 1,000 | 25,00 |  | AG-21101 |  | 25 | 0 |  |  | 12 |  |  |  |  | EQ | X | B |  | 1221 |  |  |  |  |  |  |  |  |  | VNZM |  |  |  |  |  |  |  | 0,25 | 2000 | structure +10.85 | AG-21101 | SK1221 | A01 PRESSURE EQUIPMENT | 2 DD 8530 | 2010-10-02 | 2010-11-30 | 2011-02-10 | 2010-12-23 | GMM Pfaudler | above V-21101 |  |  |  |
| HO-21101 |  | CATALYST HOLD DRUM HOIST |  | 5d | 2012-03-20 | 2012-03-24 | XB001221 SS, XN211206, XB001221 FF, V-21101, HO-21207, AG-21101 |  | -60d | 0d |  |  |  |  |  |  | HO-21101 |  | 0 | 0 |  |  | 12 |  |  |  |  | EQ | X | B |  | 1221 |  |  |  |  |  |  |  |  |  | VNZM |  |  |  |  |  |  |  |  | 1500 | concrete +16.00 |  | SK1221 |  |  |  |  |  |  |  | on Overhead Travelling Crane |  |  |  |

Notes:
- XN711206: Scope: 09.02.2011: weight: 50 ton - Mrz 50 ton
- XN801221: Current Status: 2110806 Delivery end of October 2011 (Info from Fr. Schilka 02.08.2011)
- XH00122105: Current Status: 110303 Reduce Original Duration 80d to 65d
- XH00122110: Current Status: 21.01.2011 - Siegel - Vorgдnger zur IBN HVAC / Condensat, LP-Dampf, Kьhlwasser von FF + 30 Tage Lag auf FS + 0 geдndert!
- XB001221: Current Status: 110303 (WL) Delete PRED XH0122105 Installation HVAC / 17.01.2011 (Siegel): verschiebung ergibt sich auf Grund von Verschiebungen / des Civil-Teils: "Concrete Works Building" Endtermin vom 18-Jan-11 auf den / 01-Mar-11.

| ID | WBS | Activity | Type | Duration | Start | Finish | Predecessors | Remaining | Planned start | Planned finish | Total float | Free float | Calendar | Resources | Cost | Actual cost | TB26 Ressource Budget | UDF_Weight (ton) | WEIGHT | UDF_LEVEL | UDF_TAG No | UDF_Object No | UDF_PACKAGE | UDF_SAVE ACT ID | UDF_BUDGETED LABOR UNIT | UDF_ACTUAL LABOR UNIT | Constr. Area | Zeigen/n. Zeigen | WBS Phase | WBS Discipline | WBS Objects | Subcontractor | Comments | UDF_CHECK BASELINE | Filter | UDF_PO No | UDF_DELIVERY DATE PO | UDF_DELIVERY DATE DISPATCH PLANNED | UDF_DELIVERY DATE TO SITE PLANNED | UDF_DELIVERY DATE SITE NEED DATE | UDF_SUPPLIER | Drawing Indicator | UDF_CONTRACT START DATE | UDF_CONTRACT FINISH DATE | UDF_CONTRACT ITEM | UDF_CHECK CRITICAL PATH | Department | PMT-Respons. | WBS Type of Work | Russia WBS Discipline (Russia) | Russia Construction Area | Russia WBS Phase | IMS | UPT | Russia WBS Objects | UDF_CONTRACT INDICATOR | UDF_SELECT UPDATE PROGRESS | UDF_CHECK RESOURCE DATES | PMT-Area | PMT-Schedule Org | PMT-Phase | UDF_PLANNED START | UDF_PLANNED FINISH | TB26 Semantics | TB26 Material Res Values | UDF_ELECTRICAL START | UDF_ELECTRICAL FINISH | UDF_CONTRACT FINISH DATE REV1 | UDF_CONTRACT START DATE REV1 | UDF_COMMENTS_0827 | UDF_Vendor Representatives | geplanter Start | geplantes Ende |
| --- | --- | --- | --- | --- | --- | --- | --- | --- | --- | --- | --- | --- | --- | --- | --- | --- | --- | --- | --- | --- | --- | --- | --- | --- | --- | --- | --- | --- | --- | --- | --- | --- | --- | --- | --- | --- | --- | --- | --- | --- | --- | --- | --- | --- | --- | --- | --- | --- | --- | --- | --- | --- | --- | --- | --- | --- | --- | --- | --- | --- | --- | --- | --- | --- | --- | --- | --- | --- | --- | --- | --- | --- | --- |
|  | M | **Mechanical - Rotating Equipment** |  |  | 2011-09-01 | 2012-03-19 |  |  |  |  |  |  |  |  |  |  |  |  |  |  |  |  |  |  |  |  |  |  |  |  |  |  |  |  |  |  |  |  |  |  |  |  |  |  |  |  |  |  |  |  |  |  |  |  |  |  |  |  |  |  |  |  |  |  |  |  |  |  |  |  |  |  |  |
| MI-21106 A/B |  | TEAL CONTAINER WEIGH SCALE |  | 7.5d | 2011-09-01 | 2011-09-09 | XC201222, XC401222, P3A13S1A (other project) |  |  |  | 31.5d | 38d |  | Static Equipment < 10 tons [0.6 t]; Static equipment < 10t [60 h] | 2,400 |  | 60,00 | 0,6 | 435 | concrete foundation +0.00 | MI-21106 A/B | SK1222 | A13 SCALES (MI-21-/22104/6A/B) | MI-21106 A/B | 60 | 0 | 12 | EQ | X | B | 1222 | VNZM |  |  |  |  |  |  |  |  |  |  |  |  |  |  |  |  |  |  |  |  |  |  |  |  |  |  |  |  |  |  |  |  |  |  |  |  |  |  |  |  |  |
| MI-22106 A/B |  | TEAL CONTAINER WEIGH SCALE |  | 8d | 2011-09-01 | 2011-09-09 | XC401322, XB001322 FF, XC201322, XB001322 SS, P3A13S2B (other project) |  |  |  | 37d |  |  | Static Equipment < 10 tons [0.6 t]; Static equipment < 10t [60 h] | 2,400 |  | 60,00 | 0,6 | 435 | concrete foundation +0.00 | MI-22106 A/B | SK1322 | A13 SCALES (MI-21-/22104/6A/B) | MI-22106 A/B | 60 | 0 | 13 | EQ | X | B | 1322 | VNZM |  |  |  |  |  |  |  |  |  |  |  |  |  |  |  |  |  |  |  |  |  |  |  |  |  |  |  |  |  |  |  |  |  |  |  |  |  |  |  |  |  |
| P-21102 A/B |  | FEED AND CATALYST WASTE PUMPS |  | 20d | 2011-11-07 | 2011-11-30 | XN201222, P3M08S1B (other project) |  |  |  | -4.5d | 0d |  | Rotating Equipment (w/ lube oil unit) [0.08 t]; Rotating equipment (w/ lube oil unit) [7 h] | 320 |  | 7,00 | 0,08 | 435 | steel foundation +0.00 | P-21102 A/B | SK1222 | M08 TEAL/DONOR FEED AND CATALYST WASTE PUMPS | P-21102 A/B | 7 | 0 | 12 | EQ | X | M | 1222 | VNZM | Intall Heat Tracing ET40 |  |  |  |  |  |  |  |  |  |  |  |  |  |  |  |  |  |  |  |  |  |  |  |  |  |  |  |  |  |  |  |  |  |  |  |  |  |  |  |  |
| P-22103 A/B |  | DONOR FEED PUMPS |  | 5d | 2012-02-09 | 2012-02-14 | XN301321, XM001321 FF, XM001321 SS, P3M08S2A (other project) |  |  |  | -63d | 0d |  | Rotating Equipment (w/ lube oil unit) [0.08 t]; Rotating equipment (w/ lube oil unit) [7 h] | 320 |  | 7,00 | 0,08 | 435 | concrete +0.00 | P-22103 A/B | SK1321 | M08 TEAL/DONOR FEED AND CATALYST WASTE PUMPS | P-22103 A/B | 7 | 0 | 13 | EQ | X | M | 1321 | VNZM |  | x |  |  |  |  |  |  |  |  |  |  |  |  |  |  |  |  |  |  |  |  |  |  |  |  |  |  |  |  |  |  |  |  |  |  |  |  |  |  |  |
| P-22104 |  | DONOR UNLOADING PUMP |  | 5d | 2012-02-09 | 2012-02-14 | XM001321 SS, XM001321 FF, XN301321, P3M09S2 (other project), XC20132105, XC201321 |  |  |  | -63d | 0d |  | Rotating Equipment (w/o lube oil unit) [0.26 t]; Rotating equipment (w/o lube oil unit) [26 h] | 910 |  | 26,00 | 0,04 | 435 | concrete +0.00 | P-22104 | SK1321 | M09 UNLOADING PUMPS (P-21-/22107/8) P-22104 | P-22104 | 26 | 0 | 13 | EQ | X | M | 1321 | VNZM |  | x | 1 |  |  |  |  |  |  |  |  |  |  |  |  |  |  |  |  |  |  |  |  |  |  |  |  |  |  |  |  |  |  |  |  |  |  |  |  |  |  |
| P-22106 |  | CATALYST WASTE PUMPS |  | 5d | 2012-02-09 | 2012-02-14 | XM001321 SS, XM001321 FF, P3M10S2 (other project), XN301321 |  |  |  | -63d | 0d |  | Rotating Equipment (w/ lube oil unit) [0.15 t]; Rotating equipment (w/ lube oil unit) [13.12 h] | 600 |  | 13,13 | 0,15 | 435 | concrete +0.00 | P-22106 | SK1321 | M08 TEAL/DONOR FEED AND CATALYST WASTE PUMPS | P-22106 | 13,125 | 0 | 13 | EQ | X | M | 1321 | VNZM |  | x |  |  |  |  |  |  |  |  |  |  |  |  |  |  |  |  |  |  |  |  |  |  |  |  |  |  |  |  |  |  |  |  |  |  |  |  |  |  |  |
| P-22107 |  | UNLOADING PUMPS (Alternative Donor Unloading Pump) |  | 5d | 2012-02-09 | 2012-02-14 | XC201321, P3M09S2 (other project), XN301321, XC20132105, XM001321 FF, XM001321 SS |  |  |  | -63d | 0d |  | Rotating Equipment (w/o lube oil unit) [0.16 t]; Rotating equipment (w/o lube oil unit) [16.3 h] | 570.5 |  | 16,30 | 0,025 | 435 | concrete +0.00 | P-22107 | SK1321 | M09 UNLOADING PUMPS (P-21-/22107/8) P-22107 | P-22107 | 16,3 | 0 | 13 | EQ | X | M | 1321 | VNZM |  | x | 1 |  |  |  |  |  |  |  |  |  |  |  |  |  |  |  |  |  |  |  |  |  |  |  |  |  |  |  |  |  |  |  |  |  |  |  |  |  |  |
| P-22108 |  | UNLOADING PUMPS (Mineral Oil Unloading Pump) |  | 5d | 2012-02-09 | 2012-02-14 | XM001321 SS, XC20132105, XC201321, XN301321, P3M09S2 (other project), XM001321 FF |  |  |  | -63d | 0d |  | Rotating Equipment (w/o lube oil unit) [0.16 t]; Rotating equipment (w/o lube oil unit) [16.3 h] | 570.5 |  | 16,30 | 0,025 | 435 | concrete +0.00 | P-22108 | SK1321 | M09 UNLOADING PUMPS (P-21-/22107/8) P-22108 | P-22108 | 16,3 | 0 | 13 | EQ | X | M | 1321 | VNZM |  | x | 1 |  |  |  |  |  |  |  |  |  |  |  |  |  |  |  |  |  |  |  |  |  |  |  |  |  |  |  |  |  |  |  |  |  |  |  |  |  |  |
| P-21101A/B |  | CATALYST FEED PUMPS |  | 15d | 2012-03-01 | 2012-03-19 | XN211206, V-21108, XC201221, P3M07S1 (other project) |  |  |  | -55d | 0d |  | Rotating Equipment (w/o lube oil unit) [5.66 t]; Rotating equipment (w/o lube oil unit) [566.1 h] | 19,813.5 |  | 566,10 | 0,87 | 435 | concrete +6.85 | P-21101A/B | SK1221 | M07 CATALYST FEED PUMPS (P-21-/22101A/B) | P-21101A/B | 566,1 | 0 | 12 | EQ | X | M | 1221 | VNZM |  |  |  | 2 PA 667 | 2010-10-15 | 2010-11-30 | 2010-12-15 | 2010-12-20 | Netzsch |  |  |  |  |  |  |  |  |  |  |  |  |  |  |  |  |  |  |  |  |  |  |  |  |  |  |  |  |  |  |  |  |
| P-21103 A/B |  | DONOR FEED PUMPS |  | 5d | 2012-03-01 | 2012-03-06 | XN211206, P3M08S1A (other project) |  |  |  | -45d | 10d |  | Rotating Equipment (w/ lube oil unit) [0.08 t]; Rotating equipment (w/ lube oil unit) [7 h] | 320 |  | 7,00 | 0,08 | 435 | concrete +0.00 | P-21103 A/B | SK1221 | M08 TEAL/DONOR FEED AND CATALYST WASTE PUMPS | P-21103 A/B | 7 | 0 | 12 | EQ | X | M | 1221 | VNZM |  |  |  |  |  |  |  |  |  |  |  |  |  |  |  |  |  |  |  |  |  |  |  |  |  |  |  |  |  |  |  |  |  |  |  |  |  |  |  |  |  |
| P-21106 |  | CATALYST WASTE PUMPS |  | 5d | 2012-03-01 | 2012-03-06 | XN211206, P3M10S1 (other project) |  |  |  | -45d | 10d |  | Rotating Equipment (w/ lube oil unit) [0.15 t]; Rotating equipment (w/ lube oil unit) [13.12 h] | 600 |  | 13,13 | 0,15 | 435 | concrete +0.00 | P-21106 | SK1221 | M08 TEAL/DONOR FEED AND CATALYST WASTE PUMPS | P-21106 | 13,125 | 0 | 12 | EQ | X | M | 1221 | VNZM |  |  |  |  |  |  |  |  |  |  |  |  |  |  |  |  |  |  |  |  |  |  |  |  |  |  |  |  |  |  |  |  |  |  |  |  |  |  |  |  |  |
| P-21107 |  | UNLOADING PUMPS (Alternative Donor Unloading Pump) |  | 5d | 2012-03-01 | 2012-03-06 | P3M09S1 (other project), XC201221, XC40122110, XN211206 |  |  |  | -45d | 10d |  | Rotating Equipment (w/o lube oil unit) [0.16 t]; Rotating equipment (w/o lube oil unit) [16.3 h] | 570.5 |  | 16,30 | 0,025 | 435 | concrete +0.00 | P-21107 | SK1221 | M09 UNLOADING PUMPS (P-21-/22107/8) P-21107 | P-21107 | 16,3 | 0 | 12 | EQ | X | M | 1221 | VNZM |  |  |  |  |  |  |  |  |  |  |  |  |  |  |  |  |  |  |  |  |  |  |  |  |  |  |  |  |  |  |  |  |  |  |  |  |  |  |  |  |  |
| P-21108 |  | UNLOADING PUMPS (Mineral Oil Unloading Pump) |  | 5d | 2012-03-01 | 2012-03-06 | XN211206, P3M09S1 (other project), XC201221, XC40122110 |  |  |  | -45d | 10d |  | Rotating Equipment (w/o lube oil unit) [0.16 t]; Rotating equipment (w/o lube oil unit) [16.3 h] | 570.5 |  | 16,30 | 0,025 | 435 | concrete +0.00 | P-21108 | SK1221 | M09 UNLOADING PUMPS (P-21-/22107/8) P-21108 | P-21108 | 16,3 | 0 | 12 | EQ | X | M | 1221 | VNZM |  |  |  |  |  |  |  |  |  |  |  |  |  |  |  |  |  |  |  |  |  |  |  |  |  |  |  |  |  |  |  |  |  |  |  |  |  |  |  |  |  |
| XM001221 |  | CA12 Catalyst Bldg - Install Rotating Eqpt | level of effort | 15d | 2012-03-01 | 2012-03-19 | P-21103 A/B SS, P-21103 A/B FF, P-21107 SS, P-21106 SS, P-21101A/B SS, P-21108 FF, P-21101A/B FF, P-21107 FF, P-21108 SS, P-21106 FF |  |  |  | -55d | 0d |  |  |  |  | 1 |  |  |  |  |  |  | XM001221 | 0 | 0 | 12 |  | X | M | 1221 | VNZM | E-08-01-08 |  |  |  |  |  |  |  |  | UDF_G2 | 2011-03-10 | 2011-05-10 | E-08-01-08 | SK1206 | 934 | LND | XM00 | M | 12 | X | EQ | LND | 1221 |  |  |  |  |  |  |  |  |  |  |  |  |  |  |  |  |  |  |
|  | R | **Piping** |  |  | 2011-07-19 | 2012-05-12 |  |  |  |  |  |  |  |  |  |  |  |  |  |  |  |  |  |  |  |  |  |  |  |  |  |  |  |  |  |  |  |  |  |  |  |  |  |  |  |  |  |  |  |  |  |  |  |  |  |  |  |  |  |  |  |  |  |  |  |  |  |  |  |  |  |  |  |
| XR201221 |  | CA12 Catalyst Bldg SK1206 - Piping Prefabrication |  | 90d | 2011-07-19 A | 2011-10-31 | ER491221 (other project) SS+18d | 56d |  |  | 51d | 106d |  | A/G piping prefabrication [840 Fpi]; A/G Piping (Prefab) [3150 h] | 3,059.82 |  | 3150,00 |  |  |  |  |  |  | XR201221 | 3150 | 0 | 12 |  | X | R | 1221 | VNZM |  |  |  |  |  |  |  |  |  |  |  |  |  |  | 934 | LND | XR20 | R | 12 | X | PRP | LND | 1221 | UDF_G4 | 27.8. | x | 200 | 200 | C |  |  |  |  |  |  |  |  |  |  |  |  |
| XR401221 |  | CA12 Catalyst Bldg SK1206 - Piping Installation |  | 40d | 2012-02-17 | 2012-04-05 | MI-21104 A/B FF+10d, P-21106 FF+15d, P-21107 FF+15d, HE-21108 FF+10d, V-21108 FF+10d, P-21103 A/B FF+15d, P3A25S (other project) FF+20d, P3J01AS (other project), P-21108 FF+15d, XN211206 FS-10d, P3J02AS (other project), V-21103 FF+10d, V-21106 FF+10d, MI-21101 FF+10d, V-21101 FF+10d, P-21101A/B FF+15d, P3J02DS (other project), P3J04IS (other project), HO-21101 FF+10d, AG-21101 FF+10d, XR201221 FS-20d, P3J02S (other project) FF+20d, P3J04CS1 (other project) |  |  |  | -55d | 0d |  | A/G Piping (Field) [6437.5 h]; A/G piping field installation [1030 Fpi]; Control & Shut-off valves [26 pcs]; Install Control & Shut-off Valves [136.5 h] | 16,339.38 |  | 6574,00 |  |  |  |  |  |  | XR401221 | 6574 | 0 | 12 |  | X | R | 1221 | VNZM |  |  |  |  |  |  |  |  |  |  | 2011-01-10 |  | E-06-03-03 |  | 934 | LND | XR40 | R | 12 | X | PI | LND | 1221 |  |  |  | 200 | 200 | C | 2011-04-06 |  |  |  |  |  |  |  |  |  |  |  |
| XR601221 |  | CA12 Catalyst Bldg SK1206 - Piping Pressure Tests |  | 20d | 2012-04-06 | 2012-04-28 | XR401221 FF+20d, XR605102 FF+20d, X0300020 |  |  |  | -14d | 0d |  |  |  |  | 225 |  |  |  |  |  |  | XR601221 | 0 | 0 | 12 |  | X | R | 1221 | VNZM |  |  |  |  |  |  |  |  |  |  |  |  | E-06-03-03 |  | 934 | LND | XR60 | R | 12 | X | HY | LND | 1221 |  |  |  | 200 | 200 | C |  |  |  |  |  |  |  |  |  |  |  |  |
| XR801221 |  | CA12 Catalyst Bldg SK1206 - Piping Reinstatement |  | 10d | 2012-04-30 | 2012-05-12 | XR601221 FF+10d, IMS-C-000360 FF |  |  |  | -14d | 0d |  |  |  |  | 113 |  |  |  |  |  |  | XR801221 | 0 | 0 | 12 |  | X | R | 1221 | VNZM |  |  |  |  |  |  |  |  |  |  |  | 2011-10-30 | E-06-03-03 |  | 934 | LND | XR80 | R | 12 | X | PI | LND | 1221 |  |  |  | 200 | 200 | C |  | 2012-01-30 |  |  |  |  |  |  |  |  |  |  |
|  | E | **Electrical** |  |  | 2011-04-22 | 2012-09-17 |  |  |  |  |  |  |  |  |  |  |  |  |  |  |  |  |  |  |  |  |  |  |  |  |  |  |  |  |  |  |  |  |  |  |  |  |  |  |  |  |  |  |  |  |  |  |  |  |  |  |  |  |  |  |  |  |  |  |  |  |  |  |  |  |  |  |  |
| XC911221 |  | CA12 Catalyst Bldg - Install Earthing&Lightn.Sys_CIVIL |  | 114d | 2011-04-22 A | 2011-12-28 | XC401221 FF, EE901221 (other project) | 38d | 2011-04-22 | 2011-09-05 | 108d | 51d |  | Grounding & Lightning [100 pcs]; Grounding & Lightning [1125 h] | 45,000 | 36,450 | 1125,00 |  |  |  |  |  |  | XC911221 | 1125 | 911 | 12 |  | X | C | 1221 | MO11 |  |  |  |  |  |  |  |  |  |  |  |  |  |  | 934 | LND | XE91 | C | 12 | X | EA | LND | 1221 | UDF_G4 | 27.8. | x | 200 | 200 | C |  |  |  |  |  |  |  |  |  |  |  |  |
| XE401221 |  | CA12 Catalyst Bldg - Install Cable Trays |  | 40d | 2012-03-23 | 2012-05-10 | XN801221 FS-15d, XR401221 FS-20d, EE46122110 (other project) |  |  |  | -63d | 0d |  | Cable trays/conduits [310 m]; Cable trays [930 h] | 37,200 |  | 930,00 |  |  |  |  |  |  | XE401221 | 930 | 0 | 12 |  | X | E | 1221 | URMA |  | x |  |  |  |  |  |  |  |  | 2011-05-10 | 2011-08-20 | E-15-01-09 |  | 934 | LND | XE40 | E | 12 | X | EL | LND | 1221 | UDF_G3 |  |  | 200 | 200 | C |  |  | m | 510 | 2011-07-18 | 2011-09-24 | 2011-12-20 | 2011-07-20 | to be checked |  |  |  |
| XE911224 |  | CA12 Catalyst Bldg - Install Earthing&Lightn.Sys_E/I |  | 20d | 2012-03-26 | 2012-04-17 | XN211206, AG-21101, HE-21108, HO-21101, HO-21207, MI-21101, MI-21104 A/B, V-21101, V-21103, V-21106, V-21108, P-21101A/B, P-21103 A/B, P-21106, P-21107, P-21108 |  |  |  | 61d | 123.5d |  |  |  |  | 115 |  |  |  |  |  |  | XE911224 | 0 | 0 | 12 |  | X | E | 1221 | URMA |  |  |  |  |  |  |  |  |  |  | 2011-05-10 | 2011-12-10 | E-16-07-03 |  | 934 | LND | XE91 | E | 12 | X | EA | LND | 1221 | UDF_G3 |  |  | 200 | 200 | C |  |  |  |  |  |  | 2012-05-10 | 2011-07-11 |  |  |  |  |
| XE341221 |  | CA12 Catalyst Bldg - Install Local Operation Panels |  | 20d | 2012-05-11 | 2012-06-02 | EE46122110 (other project), XE401221, XR401221 SS+20d, AG-21101, HE-21108, HO-21101, HO-21207, MI-21101, MI-21104 A/B, V-21101, V-21103, V-21106, V-21108, P-21101A/B, P-21103 A/B, P-21106, P-21107, P-21108 |  |  |  | -27d | 35.5d |  | Field Panels [3 pcs]; Field panels [60 h] | 2,400 |  | 60,00 |  |  |  |  |  |  | XE341221 | 60 | 0 | 12 |  | X | E | 1221 | URMA |  |  |  |  |  |  |  |  |  |  | 2011-05-10 | 2011-12-10 | E-16-07-03 |  | 934 | LND | XE34 | E | 12 | X | EL | LND | 1221 | UDF_G3 |  |  | 200 | 200 | C |  |  |  |  |  |  | 2012-05-10 | 2011-07-11 |  |  |  |  |
| XE801221 |  | CA12 Catalyst Bldg - Install Heat Tracing |  | 30d | 2012-05-14 | 2012-06-18 | XW501221 FF+20d, V-21108 FS+42d, XE800C00 SS, E3E1950 (other project), P3E19S (other project), CY-21202, MI-21202, PK-21211, XR401221, P-21102 A/B, XR601221 FF+10d |  |  |  | 11d | 0d |  | Electrical Heat Tracing [1000 m]; Electrical heat tracing [500 h] | 20,000 |  | 500,00 |  |  |  |  |  |  | XE801221 | 500 | 0 | 12 |  | X | E | 1221 | URMA |  |  |  |  |  |  |  |  |  |  | 2011-06-20 | 2012-03-20 | E-16-04-01 |  | 934 | LND | XE80 | E | 12 | X | HT | LND | 1221 | UDF_G3 |  |  | 200 | 200 | C |  |  |  |  |  |  | 2012-06-30 | 2011-09-15 | to be installed later | 005 |  |  |
| XE701221 |  | CA12 Catalyst Bldg - Install Lighting&SmallPower |  | 40d | 2012-05-23 | 2012-07-09 | P3E03S2 (other project) FF+20d, P3E09S (other project), EE761221 (other project), XC401221, XE401221, XP341610 FS+50d, XJ421221 |  |  |  | -7d | 0d |  | Cable Pulling [700 m]; Lighting illuminates [70 pcs]; Lighting (iluminates) [700 h]; Cable pulling [350 h] | 42,000 |  | 1050,00 |  |  |  |  |  |  | XE701221 | 1050 | 0 | 12 |  | X | E | 1221 | URMA |  |  | x |  |  |  |  |  |  |  | 2011-05-10 | 2012-01-31 | E-16-03-01 |  | 934 | LND | XE70 | E | 12 | X | EL | LND | 1221 |  |  |  | 200 | 200 | C |  |  |  |  |  |  | 2012-05-10 | 2011-08-15 |  |  |  |  |
| XE501221 |  | CA12 Catalyst Bldg - Cable Pulling Electric |  | 60d | 2012-06-09 | 2012-08-20 | XE401221, XE505102 SS+10d, P3E15AS (other project), XE500C01, P3E15CS (other project), XE501204 SS, EE561221 (other project), P3E15BS (other project), XE505401 SS+12d, XE501201 SS |  |  |  | -62.5d | 0d | TB26 - V - Construct-Winter partly * | Cable Pulling [5300 m]; Cable pulling [2650 h] | 106,000 |  | 2650,00 |  |  |  |  |  |  | XE501221 | 2650 | 0 | 12 |  | X | E | 1221 | URMA |  |  |  |  |  |  |  |  |  |  | 2011-05-20 | 2012-02-10 | E-16-01-01 |  | 934 | LND | XE50 | E | 12 | X | EL | LND | 1221 | UDF_G3 |  |  | 200 | 200 | C |  |  | m | 5500 | 2011-09-26 | 2011-12-05 | 2012-07-01 | 2011-10-01 |  |  |  |  |
| XE921221 |  | CA12 Catalyst Bldg - Install Fire Detection Sys |  | 60d | 2012-07-10 | 2012-09-17 | XC501221, XH00122105, XE701221, XJ421221 |  |  |  | 164.5d | 0d |  | Fire Detection System; Fire detection system |  |  | 0,00 |  |  |  |  |  |  | XE921221 | 0 | 0 | 12 |  | X | E | 1221 |  |  | x | x |  |  |  |  |  |  |  | 2011-05-10 | 2011-12-10 | E-16-07-03 |  | 934 | UIO | XE92 | E | 12 | X | FGDS | LND | 1221 |  |  |  | 200 | 200 | C |  |  |  |  |  |  |  |  |  |  | 2012-02-13 | 2012-07-09 |
| XE961221 |  | CA12 Catalyst Bldg - Install Communication Sys |  | 60d | 2012-07-10 | 2012-09-17 | XC501221, E3E1350 (other project), XH00122105, XJ421221, P3E13S (other project), XE921221 SS, XE701221 |  |  |  | 164.5d |  |  | Communication System |  |  | 0,00 |  |  |  |  |  |  | XE961221 | 0 | 0 | 12 |  | X | E | 1221 |  |  | x | x |  |  |  |  |  |  |  | 2011-05-10 | 2011-12-10 | E-16-07-03 |  | 934 | LND | XE96 | E | 12 | X | CS | LND | 1221 |  |  |  | 200 | 200 | C |  |  |  |  |  |  |  |  |  |  | 2012-02-13 | 2012-07-09 |
| XE601221 |  | CA12 Catalyst Bldg - Cable Termination & Testing |  | 50d | 2012-07-16 | 2012-09-12 | XE341221, XE501221 FF+20d, AG-21101, HE-21108, HO-21101, HO-21207, MI-21101, MI-21104 A/B, V-21101, V-21103, V-21106, V-21108, P-21101A/B, P-21103 A/B, P-21106, P-21107, P-21108 |  |  |  | -62.5d | 0d |  | Cable connecting [40 pcs]; Cable connecting [100 h] | 4,000 |  | 100,00 |  |  |  |  |  |  | XE601221 | 100 | 0 | 12 |  | X | E | 1221 | URMA |  |  |  |  |  |  |  |  |  |  | 2011-04-20 | 2011-11-30 | E-16-02-01 |  | 934 | LND | XE60 | E | 12 | X | ET | LND | 1221 | UDF_G3 |  |  | 200 | 200 | C |  |  |  |  |  |  | 2012-08-14 | 2011-12-10 |  |  |  |  |

Notes:
- XM001221: Current Status: 110303 (WL) Add PRED XC201221 EqptFdtn; delete PRED XH0122105 Installation / HVAC / 17.01.2011 (Siegel): verschiebung ergibt sich auf Grund von Verschiebungen / des Civil-Teils: "Concrete Works Building" Endtermin vom 18-Jan-11 auf den / 01-Mar-11.
- XR401221: Current Status: 110831: OD 120 > 40 (M. Siegel)
- XR601221: Current Status: 110831: OD 60 > 20 (M. Siegel)
- XR801221: Current Status: 110831: OD 40 > 10 (M. Siegel)
- XE341221: P3 Activity Log Info: Local Control Panels
- XE921221: Scope: CA12 Polymerization Line 1 / FDS - 49 external sensors / GDS - 29 external sensors / DS + SAME
- XE961221: Scope: CA12 Polymerization Line 1 / FDS - 49 external sensors / GDS - 29 external sensors / DS + SAME

| ID | WBS | Activity | Type | Duration | Start | Finish | Predecessors | Complete | Planned start | Planned finish | Total float | Free float | Constraint | Calendar | Resources | Cost | Actual cost | TB26 Ressource Budget | UDF_CONTRACT START DATE | UDF_CONTRACT FINISH DATE | UDF_CONTRACT ITEM | UDF_CONTRACT INDICATOR | UDF_CONTRACT FINISH DATE REV1 | UDF_CONTRACT START DATE REV1 | UDF_SAVE ACT ID | UDF_BUDGETED LABOR UNIT | UDF_ACTUAL LABOR UNIT | UDF_COMMENTS_0827 | Department | Constr. Area | PMT-Area | PMT-Schedule Org | PMT-Phase | PMT-Respons. | WBS Phase | WBS Discipline | WBS Type of Work | WBS Objects | Russia WBS Discipline (Russia) | Russia Construction Area | Russia WBS Phase | IMS | UPT | Russia WBS Objects | Subcontractor | Filter | TB26 Semantics | TB26 Material Res Values | UDF_ELECTRICAL START | UDF_ELECTRICAL FINISH | UDF_CHECK BASELINE | UDF_PENALIZED FINISH | Civil item | UDF_CHECK CRITICAL PATH | UDF_SELECT UPDATE PROGRESS | 4 week lookahead | UDF_EXPECTED START | UDF_EXPECTED FINISH | Zeigen/n. Zeigen | Comments | UDF_CHECK RESOURCE DATES | UDF_Concrete | UDF_SELECT |
| --- | --- | --- | --- | --- | --- | --- | --- | --- | --- | --- | --- | --- | --- | --- | --- | --- | --- | --- | --- | --- | --- | --- | --- | --- | --- | --- | --- | --- | --- | --- | --- | --- | --- | --- | --- | --- | --- | --- | --- | --- | --- | --- | --- | --- | --- | --- | --- | --- | --- | --- | --- | --- | --- | --- | --- | --- | --- | --- | --- | --- | --- | --- | --- |
|  | J | **Instrumentation** |  |  | 2012-03-26 | 2012-11-03 |  |  |  |  |  |  |  |  |  |  |  |  |  |  |  |  |  |  |  |  |  |  |  |  |  |  |  |  |  |  |  |  |  |  |  |  |  |  |  |  |  |  |  |  |  |  |  |  |  |  |  |  |  |  |  |  |  |
| XJ301221 |  | CA12 Catalyst Bldg - Install Field Instruments |  | 60d | 2012-03-26 | 2012-06-05 | P3J12DS (other project), P3J04AS (other project), P3J12AS (other project), P3J07AS (other project), P3J14AS (other project), XR801221 FF, P3J13CS (other project), P3J13S (other project), P3J12BS (other project), P3J14BS (other project), P3J04BS (other project), P3J14S (other project), P3J13AS (other project), EJ361221 (other project), P3J13BS (other project), P3J05S (other project), P3J04ES (other project), XR401221 SS+20d, AG-21101, HE-21108, HO-21101, HO-21207, MI-21101, MI-21104 A/B, V-21101, V-21103, V-21106, V-21108, P-21101A/B, P-21103 A/B, P-21106, P-21107, P-21108 |  |  |  | -34d | 0d |  |  | Field Instruments [128 pcs]; Install field instruments [705 h] | 28,160 |  | 704,00 | 2011-05-10 | 2012-03-01 | E-17-04-03 | UDF_G3 | 2012-08-15 | 2011-07-25 | XJ301221 | 705 | 0 | to be checked | 934 | 12 | 200 | 200 | C | LND | X | J | XJ30 | 1221 | J | 12 | X | IN | LND | 1221 | URMA |  |  |  |  |  |  |  |  |  |  |  |  |  |  |  |  |  |  |
| XJ321221 |  | CA12 Catalyst Bldg - Install Junction Boxes |  | 30d | 2012-03-26 | 2012-04-28 | P3J06FS (other project), P3J06ES (other project) FS+14d, EJ321221 (other project), XR401221 SS+20d, AG-21101, HE-21108, HO-21101, HO-21207, MI-21101, MI-21104 A/B, V-21101, V-21103, V-21106, V-21108, P-21101A/B, P-21103 A/B, P-21106, P-21107, P-21108 |  |  |  | -60d | 3d |  |  | Junction Boxes/Cabinets/Panels [25 pcs]; Install Junction Boxes/ Cabinets/ Panels [625 h] | 25,000 |  | 625,00 | 2011-05-10 | 2012-03-01 | E-17-04-03 | UDF_G3 | 2012-08-15 | 2011-07-25 | XJ321221 | 625 | 0 | to be checked | 934 | 12 | 200 | 200 | C | LND | X | J | XJ32 | 1221 | J | 12 | X | IN | LND | 1221 | URMA |  |  |  |  |  |  |  |  |  |  |  |  |  |  |  |  |  |  |
| XJ421221 |  | CA12 Catalyst Bldg - Install Secondary Cable Trays |  | 30d | 2012-04-16 | 2012-05-22 | XJ321221 FS-15d, XR401221 SS+20d, XE401221 FS-20d, EJ46122110 (other project), AG-21101, HE-21108, HO-21101, HO-21207, MI-21101, MI-21104 A/B, V-21101, V-21103, V-21106, V-21108, P-21101A/B, P-21103 A/B, P-21106, P-21107, P-21108 |  |  |  | -63d | 0d |  |  | Secondary cable trays [240 m]; Install secondary cable trays [900 h] | 36,000 |  | 900,00 | 2011-05-10 | 2011-08-20 | E-15-01-09 |  | 2011-12-20 | 2011-07-20 | XJ421221 | 900 | 0 | to be checked | 934 | 12 | 200 | 200 | C | LND | X | J | XJ42 | 1221 | J | 12 | X | IN | LND | 1221 | URMA | x | m | 450 | 2011-07-18 | 2011-09-24 | x |  |  |  |  |  |  |  |  |  |  |  |  |
| XJ441221 |  | CA12 Catalyst Bldg - Install Conduits to Instrm |  | 60d | 2012-05-04 | 2012-07-14 | XJ321221, AG-21101, HE-21108, HO-21101, HO-21207, MI-21101, MI-21104 A/B, V-21101, V-21103, V-21106, V-21108, P-21101A/B, P-21103 A/B, P-21106, P-21107, P-21108, XR401221 SS+20d, XJ421221 FS-15d, XE401221 FS-20d |  |  |  | -63d | 0d |  |  |  |  |  |  | 2011-05-10 | 2012-03-01 | E-17-04-03 |  | 2012-08-15 | 2011-07-25 | XJ441221 | 0 | 0 | to be checked | 934 | 12 | 200 | 200 | C | LND | X | J | XJ44 | 1221 | J | 12 | X | IN | LND | 1221 | URMA |  |  |  |  |  |  |  |  |  |  |  |  |  |  |  |  |  |  |
| XJ701221 |  | CA12 Catalyst Bldg - Instrument Tubing |  | 30d | 2012-05-25 | 2012-06-29 | XJ301221 FF+20d, XR401221 |  |  |  | -34d | 28d |  |  |  |  |  |  | 2011-05-10 | 2012-03-01 | E-17-04-03 |  | 2012-08-15 | 2011-07-25 | XJ701221 | 0 | 0 |  | 934 | 12 | 200 | 200 | C | LND | X | J | XJ70 | 1221 | J | 12 | X | IN | LND | 1221 | URMA |  |  |  |  |  |  |  |  |  |  |  |  |  |  |  |  |  |  |
| XJ391221 |  | CA12 Catalyst Bldg - Install Earthing Field Eqpt |  | 30d | 2012-06-09 | 2012-07-14 | XJ301221 FS-30d, XJ421221 FS-15d, XJ441221 FS-30d |  |  |  | -47d | 15d |  |  |  |  |  |  | 2011-05-10 | 2012-03-01 | E-17-04-03 | UDF_G3 | 2012-08-15 | 2011-07-25 | XJ391221 | 0 | 0 |  | 934 | 12 | 200 | 200 | C | LND | X | J | XJ39 | 1221 | J | 12 | X | IN | LND | 1221 | URMA |  |  |  |  |  |  |  |  |  |  |  |  |  |  |  |  |  |  |
| XJ541221 |  | CA12 Catalyst Bldg - Pulling Singlecore Cables |  | 60d | 2012-06-09 | 2012-08-18 | XJ301221 FF+20d, XJ441221 FS-30d, EJ801221 (other project), XE500C01, X3J130 FF, XJ421221 |  |  |  | -62d | 0d |  | TB26 - V - Construct-Winter partly * | Singlecore cables [11000 m]; Pull singlecore cables [8250 h] | 330,000 |  | 8250,00 | 2011-05-10 | 2012-03-01 | E-17-04-03 |  | 2012-08-15 | 2011-07-25 | XJ541221 | 8250 | 0 |  | 934 | 12 | 200 | 200 | C | LND | X | J | XJ54 | 1221 | J | 12 | X | IN | LND | 1221 | URMA |  | m | 10567 | 2011-11-26 | 2012-02-10 |  |  |  |  |  |  |  |  |  |  |  |  |  |
| XJ521221 |  | CA12 Catalyst Bldg - Pulling Multicore Cables |  | 50d | 2012-06-13 | 2012-08-10 | XJ321221 SS+20d, XJ525102 SS+12d, XE500C01, XJ521204 SS+10d, XJ525401 SS+15d, XE401221 |  |  |  | -22.5d | 0d |  | TB26 - V - Construct-Winter partly * | Pull multicore cables [2550 h]; Multicore cables [5100 m] | 102,000 |  | 2550,00 | 2011-05-20 | 2012-03-10 | E-17-01-01 |  | 2012-06-16 | 2011-11-01 | XJ521221 | 2550 | 0 | to be checked | 934 | 12 | 200 | 200 | C | LND | X | J | XJ52 | 1221 | J | 12 | X | IN | LND | 1221 | URMA |  | m | 3700 | 2011-09-14 | 2011-11-23 |  |  |  |  |  |  |  |  |  |  |  |  |  |
| XJ621221 |  | CA12 Catalyst Bldg - Termin Multicore Cables |  | 40d | 2012-07-12 | 2012-08-28 | XJ521221 FF+15d, XJ321221 |  |  |  | -22.5d | 38d |  |  | Termination Field [705 mhr]; Termination field [705 h] | 70,500 |  | 705,00 | 2011-05-20 | 2012-03-10 | E-17-01-01 |  | 2012-06-16 | 2011-11-01 | XJ621221 | 705 | 0 |  | 934 | 12 | 200 | 200 | C | LND | X | J | XJ62 | 1221 | J | 12 | X | IN | LND | 1221 | URMA |  |  |  |  |  |  |  |  |  |  |  |  |  |  |  |  |  |  |
| XJ641221 |  | CA12 Catalyst Bldg - Termin Singlecore Cables |  | 50d | 2012-07-16 | 2012-09-11 | XJ701221 FS-15d, XJ541221 FS-30d, XJ391221 FS-15d, XJ301221 FS-30d, XJ321221 FS-15d |  |  |  | -62d | 0.5d |  |  | Termination Field [705 mhr]; Termination field [705 h] | 70,500 |  | 705,00 | 2011-05-10 | 2012-03-01 | E-17-04-03 |  | 2012-08-15 | 2011-07-25 | XJ641221 | 705 | 0 |  | 934 | 12 | 200 | 200 | C | LND | X | J | XJ64 | 1221 | J | 12 | X | IN | LND | 1221 | URMA |  |  |  |  |  |  |  |  |  |  |  |  |  |  |  |  |  |  |
| XJ801221 |  | CA12 Catalyst Bldg - Inspections/ Mech. Acceptance/ Loop Checks |  | 60d | 2012-08-25 | 2012-11-03 | XJ701221 SS, XJ391221 SS+10d, X3J100 FF, XE601221 FS-25d, XJ641221 FF+20d, X030410030, X3J120, XJ621221 FF+20d |  |  |  | -60.5d | 22d |  |  | Loop Checks [350 pcs]; Loop checks [1750 h] | 70,000 |  | 1750,00 | 2011-06-10 | 2012-04-30 | E-17-02-01 |  | 2012-08-18 | 2012-03-01 | XJ801221 | 1750 | 0 |  | 934 | 12 | 200 | 200 | C | LND | X | J | XJ80 | 1221 | J | 12 | X | LT | LND | 1221 | URMA |  |  |  |  |  |  | 2012-08-18 |  |  |  |  |  |  |  |  |  |  |  |
|  | S | **Safety & Environment** |  |  |  |  |  |  |  |  |  |  |  |  |  |  |  |  |  |  |  |  |  |  |  |  |  |  |  |  |  |  |  |  |  |  |  |  |  |  |  |  |  |  |  |  |  |  |  |  |  |  |  |  |  |  |  |  |  |  |  |  |  |
|  | W | **Painting** |  |  | 2012-03-14 | 2012-05-24 |  |  |  |  |  |  |  |  |  |  |  |  |  |  |  |  |  |  |  |  |  |  |  |  |  |  |  |  |  |  |  |  |  |  |  |  |  |  |  |  |  |  |  |  |  |  |  |  |  |  |  |  |  |  |  |  |  |
| XW501221 |  | CA12 Catalyst Bldg - Surf.Protection Piping |  | 60d | 2012-03-14 | 2012-05-24 | XR801221 FF+10d, XR201221 SS |  |  |  | 11d | 0d |  |  | Piping painting [284 sqm]; Piping painting [710 h] | 440.5 |  | 710,00 |  |  |  |  |  |  | XW501221 | 710 | 0 |  | 934 | 12 | 200 | 200 | C | LND | X | W | XW50 | 1221 | W | 12 | X | PA | LND | 1221 | VNZM |  |  |  |  |  |  |  |  |  |  |  |  |  |  |  |  |  |  |
|  | V | **Insulation** |  |  | 2012-04-12 | 2012-08-15 |  |  |  |  |  |  |  |  |  |  |  |  |  |  |  |  |  |  |  |  |  |  |  |  |  |  |  |  |  |  |  |  |  |  |  |  |  |  |  |  |  |  |  |  |  |  |  |  |  |  |  |  |  |  |  |  |  |
| XV301221 |  | CA12 Catalyst Bldg - Insulation Equipment |  | 85d | 2012-04-12 | 2012-07-23 | XV300C00 SS, XE801221 FF+30d |  |  |  | 16d | 8d |  | TB26 - V - Construct-Winter partly * | Equipment insulation [150 sqm]; Equipment insulation [1875 h] | 314.85 |  | 1875,00 |  | 2012-03-30 | E-13-03 |  |  |  | XV301221 | 1875 | 0 |  | 934 | 12 | 200 | 200 | C | LND | X | V | XV30 | 1221 | V | 12 | X | INS | LND | 1221 | VNZM |  |  |  |  |  |  |  |  |  |  |  |  |  |  |  |  |  |  |
| XV501221 |  | CA12 Catalyst Bldg - Insulation Piping |  | 90d | 2012-04-30 | 2012-08-15 | XV301221 FF+12d, XE801221 FF+20d, XR601221 SS+20d |  |  |  | 8d | 90.5d |  | TB26 - V - Construct-Winter partly * | Piping insulation [250 sqm]; Piping insulation [1875 h] | 1,253.49 |  | 1875,00 |  | 2012-04-30 | E-13-01 |  |  |  | XV501221 | 1875 | 0 |  | 934 | 12 | 200 | 200 | C | LND | X | V | XV50 | 1221 | V | 12 | X | INS | LND | 1221 | VNZM |  |  |  |  |  |  |  |  |  |  |  |  |  |  |  |  |  |  |
|  | 22 | **CA12 - Teal Building Line 1** |  |  | 2010-08-19 | 2012-11-16 |  |  |  |  |  |  |  |  |  |  |  |  |  |  |  |  |  |  |  |  |  |  |  |  |  |  |  |  |  |  |  |  |  |  |  |  |  |  |  |  |  |  |  |  |  |  |  |  |  |  |  |  |  |  |  |  |  |
|  | C | **Civil Work** |  |  | 2010-08-19 | 2012-06-07 |  |  |  |  |  |  |  |  |  |  |  |  |  |  |  |  |  |  |  |  |  |  |  |  |  |  |  |  |  |  |  |  |  |  |  |  |  |  |  |  |  |  |  |  |  |  |  |  |  |  |  |  |  |  |  |  |  |
| XC20122205 |  | CA12 Teal Bldg SK1202 - Concrete Works Building Fdtn +0.00 |  | 173d | 2010-08-19 A | 2011-05-16 A | XC20120105 FS+25d, XC151200, EC48122203 (other project) FS+10d | 100% |  |  |  |  |  | TB26 - V - Construct-Winter partly * | Concrete works [50 cbm]; Concrete works [1500 h] | 60,000 | 60,000 | 1500,00 |  |  |  |  |  |  | XC20122205 | 1500 | 1500 |  | 934 | 12 | 200 | 200 | C | MO03 | X | C | XC20 | 1222 | C | 12 | X | OB | LND | 1222 | MO11 |  |  |  |  |  |  |  |  |  |  |  |  |  |  |  |  |  |  |
| XC401222 |  | CA12 Teal Bldg SK1202 - Concrete Works Building |  | 210d | 2010-10-26 A | 2011-08-27 A | XC20122205 FS+25d, P3C02D2 (other project), EC48122205 (other project) | 100% | 2010-10-26 | 2011-09-05 |  |  |  | TB26 - V - Construct-Winter partly * | Concrete works [150 cbm]; Concrete works [4500 h] | 5,912.7 |  | 4500,00 |  |  |  | UDF_G4 |  |  | XC401222 | 4500 | 1500 |  | 934 | 12 | 200 | 200 | C | MO04 | X | C | XC40 | 1222 | C | 12 | X | OB | LND | 1222 | MO11 |  |  |  |  |  |  |  | x | SK1202 | 27.8. | x |  |  |  |  |  |  |  |
| XC40122210 |  | CA12 Teal Bldg SK1202 - Concrete Works Building finished | milestone | 0d | 2011-07-30 A | 2011-07-30 A | XC401222 FF | 100% |  |  |  |  |  | TB26 - V - Construct-Winter partly * |  |  |  |  |  |  |  |  |  |  | XC40122210 | 0 | 0 |  | 934 | 12 | 200 | 200 | C | MO04 | X | C | XC40 | 1222 | C | 11 | X | OB | LND | 1110 | MO11 |  |  |  |  |  |  |  |  | SK1202 |  |  | 2011-06-07 | 2011-06-07 | D |  |  |  |  |
| XC201222 |  | CA12 Teal Bldg SK1202 - Concrete Works EqptFdtn |  | 0d | 2011-08-19 A | 2011-08-26 A | XC20122205, EC281222 (other project) FS+20d, EC45122205 (other project), XC401222 FF-5d | 100% | 2011-08-26 | 2011-08-26 |  |  | start on or after 2011-09-05 | TB26 - V - Construct-Winter partly * | Concrete works |  |  | 1500,00 |  |  |  |  |  |  | XC201222 | 1500 | 0 |  | 934 | 12 | 200 | 200 | C | MO04 | X | C | XC20 | 1222 | C | 12 | X | mis | LND | 1222 | MO11 | 1 |  |  |  |  |  |  |  | SK1202 | 27.8. |  |  |  |  | Start 5.9. | ?? actual start |  |  |
| XC501222 |  | CA12 Teal Bldg SK1202 - Finishing Works Rooms |  | 130d | 2011-12-27 | 2012-06-07 | XC001222, EC501222 (other project), XC401222, XC911222 FF+20d, XC510C00 FS+15d, XC40122210 |  |  |  | 19.5d | 0d |  |  | Finishing Works - Teal Buildings CA12/13 [25025 mhr]; Finishing Works - Teal buildings [25025 h] | 2,502,500 |  | 25025,00 |  |  |  |  |  |  | XC501222 | 25025 | 0 |  | 934 | 12 | 200 | 200 | C | CiC | X | C | XC50 | 1222 | C | 12 | X | OB | LND | 1222 |  |  |  |  |  |  |  |  |  | SK1202 |  |  |  |  |  |  |  | 1 | XC50 |
| XC501222_1 |  | CA12 Teal Bldg SK1202 - Plastering and Painting (Finishing Works) |  | 20d | 2011-12-27 | 2012-01-26 | XC501222 SS |  |  |  | 56.5d | 0d |  |  |  |  |  | 25025,00 |  |  |  |  |  |  | XC501222 | 25025 | 0 |  | 934 | 12 | 200 | 200 | C | CiC | X | C | XC50 | 1222 | C | 12 | X | OB | LND | 1222 |  |  |  |  |  |  |  |  |  | SK1202 |  |  |  |  |  |  |  | 1 |  |

Notes:
- XW501221: P3 Activity Log Info: Clarification Surface Protection during Prefab
- XC401222: Current Status: 110303 (WL) Resume Date 09.05.11 nach Vorgabe H. Bucher / 19.02.2011 (O.Siegel): laut Terminplan vom MO11 vom 16-Feb-11 werden die / Arbeiten am 01-Mrz-11 wierderaufgenommen. Das Enddatum wurde mit / 23-Mai-11 datiert. / 12.01.2011 (Oxana): Enddatum auf den 01.03.2011 verschoben / (Abstimmungsgesprдch mit Mostostroy vom 11-01-2011). Die Ressourcen / entsprechend CPMR-Daten auf 60% angepasst
- XC40122210: P3 Activity Log Info: excl. openings for Compressor Lifts / Current Status: 17.01.2011 (Siegel): die Verschiebung basiert auf der / Civil-Verschiebung: "Conrete Works Building" Endtermin vom 18-Jan-11 auf / den 01-Mar-11. Als Folge verschibt sich die HVAC-Montage.
- XC201222: Current Status: 12.01.11 (Oxana): den Lag zur XC401222 von / urspruenglich 10 auf 20 Tage geдndet.
- XC501222: Current Status: 13.01.11 Volkmann- Finishing Works in Warmperiode in Absprache mit / MO11 verschoben mit weichem Constrain.
- XC501222_1: Current Status: 13.01.11 Volkmann- Finishing Works in Warmperiode in Absprache mit / MO11 verschoben mit weichem Constrain.

| ID | WBS | Activity | Type | Duration | Start | Finish | Predecessors | Complete | Remaining | Planned start | Planned finish | Total float | Free float | Constraint | Calendar | Resources | Cost | Actual cost | TB26 Ressource Budget | UDF_SAVE ACT ID | UDF_CHECK BASELINE | UDF_BUDGETED LABOR UNIT | UDF_ACTUAL LABOR UNIT | Department | Type of Work | Constr. Area | PMT-Area | PMT-Schedule Org | PMT-Phase | PMT-Respons. | Zeigen/n. Zeigen | WBS Phase | WBS Discipline | WBS Type of Work | WBS Objects | Russia WBS Discipline (Russia) | Russia Construction Area | Russia WBS Phase | IMS | UPT | Russia WBS Objects | UDF_SELECT UPDATE PROGRESS | Comments | UDF_CHECK CRITICAL PATH | TB26 Semantics | Inquiry/Order No | Subcontractor | Filter | UDF_SELECT | UDF_CONTRACT START DATE | UDF_CONTRACT FINISH DATE | UDF_L3 START DATE | UDF_L3 FINISH DATE | Drawing Indicator | UDF_CONTRACT ITEM | UDF_Weight (ton) | WEIGHT | UDF_LEVEL | UDF_PO No | UDF_TAG No | UDF_Object No | UDF_DELIVERY DATE PO | UDF_DELIVERY DATE DISPATCH PLANNED | UDF_DELIVERY DATE TO SITE PLANNED | UDF_DELIVERY DATE SITE NEED DATE | UDF_PACKAGE | UDF_SUPPLIER | UDF_CONTRACT INDICATOR | UDF_CHECK RESOURCE DATES | UDF_PLANNED START | UDF_PLANNED FINISH | UDF_CONTRACT FINISH DATE REV1 | UDF_CONTRACT START DATE REV1 | TB26 Material Res Values | UDF_ELECTRICAL START | UDF_ELECTRICAL FINISH | UDF_Vendor Representatives | UDF_COMMENTS_0827 | geplanter Start | geplantes Ende |
| --- | --- | --- | --- | --- | --- | --- | --- | --- | --- | --- | --- | --- | --- | --- | --- | --- | --- | --- | --- | --- | --- | --- | --- | --- | --- | --- | --- | --- | --- | --- | --- | --- | --- | --- | --- | --- | --- | --- | --- | --- | --- | --- | --- | --- | --- | --- | --- | --- | --- | --- | --- | --- | --- | --- | --- | --- | --- | --- | --- | --- | --- | --- | --- | --- | --- | --- | --- | --- | --- | --- | --- | --- | --- | --- | --- | --- | --- | --- | --- | --- |
|  | N | **Structural Steel** |  |  | 2011-02-01 | 2011-12-27 |  |  |  |  |  |  |  |  |  |  |  |  |  |  |  |  |  |  |  |  |  |  |  |  |  |  |  |  |  |  |  |  |  |  |  |  |  |  |  |  |  |  |  |  |  |  |  |  |  |  |  |  |  |  |  |  |  |  |  |  |  |  |  |  |  |  |  |  |  |  |  |  |  |  |
| XN701202 |  | CA12 Teal Bldg SK1202 - KMD Assy Drawings | milestone | 0d | 2011-02-01 A | 2011-02-01 A |  | 100% |  |  |  |  |  | finish on 2011-01-31 | TB26 - V - Construct-Winter partly * |  |  |  | 22t | XN701202 | x | 0 | 0 | 934 | XNK | 12 | 200 | 200 | C | LND | KMD | X | N | XN05 | 1222 | N | 12 | X | SS | LND | 1222 |  |  |  |  |  |  |  |  |  |  |  |  |  |  |  |  |  |  |  |  |  |  |  |  |  |  |  |  |  |  |  |  |  |  |  |  |  |  |  |
| XN711202 |  | CA12 Teal Bldg SK1202 - Steel Deliveries | milestone | 0d | 2011-07-30 A | 2011-07-30 A |  | 100% |  |  |  |  |  | finish on or after 2011-07-30 | TB26 - 3 - Construction Normal 7days * CA17 |  |  |  | 22t | XN711202 |  | 0 | 0 | 934 | XNK | 12 | 200 | 200 | C | LND | SD | X | N | XN06 | 1222 | N | 12 | X | SS | LND | 1222 | 27.8. |  |  |  |  |  |  |  |  |  |  |  |  |  |  |  |  |  |  |  |  |  |  |  |  |  |  |  |  |  |  |  |  |  |  |  |  |  |  |
| XN201222 |  | CA12 Teal Bldg SK1202 - Install Prim Steel / Eqpt Platforms |  | 10d | 2011-10-24 | 2011-11-07 | XC401222, MI-21106 A/B, P3N012D (other project) FS+10d, XN701202, XN711202 FS+10d, P3N02PN (other project) |  |  |  |  | -6.5d | 0d | start on or after 2011-10-24 | TB26 - V - Construct-Winter partly * | Piperacks, Main Structures [11 t]; Piperacks, Main structures [467.5 h] | 18,700 |  | 467,50 | XN201222 |  | 467,5 | 0 | 934 | XNK | 12 | 200 | 200 | C | LND |  | X | N | XN30 | 1222 | N | 12 | X | SS | LND | 1110 |  | 4 t from 11 t at site | SK1202 | t | 2DC8460 | ChSK |  |  |  |  |  |  |  |  |  |  |  |  |  |  |  |  |  |  |  |  |  |  |  |  |  |  |  |  |  |  |  |  |  |
| XN301222 |  | CA12 Teal Bldg SK1202 - Install Railings,Ladders,etc. |  | 10d | 2011-11-07 | 2011-11-23 | XN201222 FF+10d |  |  |  |  | -6.5d | 0d |  | TB26 - V - Construct-Winter partly * | Ladders & platforms [3 t]; Ladders & platforms [300 h] | 12,000 |  | 300,00 | XN301222 |  | 300 | 0 | 934 | XNK | 12 | 200 | 200 | C | LND |  | X | N | XN40 | 1222 | N | 12 | X | SS | LND | 1110 |  |  | SK1202 |  |  | ChSK |  |  |  |  |  |  |  |  |  |  |  |  |  |  |  |  |  |  |  |  |  |  |  |  |  |  |  |  |  |  |  |  |  |
| XN601222 |  | CA12 Teal Bldg SK1202 - Install Gratings |  | 10d | 2011-11-07 | 2011-11-23 | MI-21106 A/B, XN301222 FF |  |  |  |  | -6.5d | 0d |  | TB26 - V - Construct-Winter partly * | Grating [20 sqm]; Grating [75 h] | 3,000 |  | 75,00 | XN601222 |  | 75 | 0 | 934 | XNK | 12 | 200 | 200 | C | LND |  | X | N | XN60 | 1222 | N | 12 | X | SS | LND | 1110 |  |  | SK1202 |  |  | ChSK |  |  |  |  |  |  |  |  |  |  |  |  |  |  |  |  |  |  |  |  |  |  |  |  |  |  |  |  |  |  |  |  |  |
| XN801222 |  | CA12 Teal Bldg SK1202 - Cladding Works Walls/Roof |  | 25d | 2011-11-07 | 2011-12-27 | XN201222 |  |  |  |  | 6.5d | 0d |  | TB26 - V - Construct-Winter partly * | Cladding [290 sqm]; Cladding [1450 h] | 58,000 |  | 1450,00 | XN801222 |  | 1450 | 0 | 934 | XNK | 12 | 200 | 200 | C | LND | D | X | N | XN80 | 1222 | N | 12 | X | SS | LND | 1710 |  |  | SK1202 |  |  | ChSK |  |  |  |  |  |  |  |  |  |  |  |  |  |  |  |  |  |  |  |  |  |  |  |  |  |  |  |  |  |  |  |  |  |
|  | H | **HVAC** |  |  | 2012-01-26 | 2012-06-20 |  |  |  |  |  |  |  |  |  |  |  |  |  |  |  |  |  |  |  |  |  |  |  |  |  |  |  |  |  |  |  |  |  |  |  |  |  |  |  |  |  |  |  |  |  |  |  |  |  |  |  |  |  |  |  |  |  |  |  |  |  |  |  |  |  |  |  |  |  |  |  |  |  |  |
| XH00122205 |  | CA12 Teal Bldg - Installation HVAC |  | 60d | 2012-01-26 | 2012-04-07 | XC40122210, XC401222, XC501222 SS+20d, EH30122205 (other project), XH000000 FF, P3H01D (other project) FS+20d, P3H01SE (other project), XC501222_1 |  |  |  |  | 56.5d | 0d |  |  | HVAC - Teal Buildings CA12/13 [7475 mhr]; HVAC - Teal buildings [7475 h] |  |  | 7475,00 | XH00122205 |  | 7475 | 0 | 934 |  | 12 | 200 | 200 | C | LND |  | X | H | XH00 | 1222 | H | 12 | X | hvac | LND | 1222 |  |  | SK1202 |  |  | ARMO | x | REL XC50 | 2011-02-20 | 2011-04-30 | 2011-05-13 | 2011-07-13 |  |  |  |  |  |  |  |  |  |  |  |  |  |  |  |  |  |  |  |  |  |  |  |  |  |  |  |
| XH00122210 |  | CA12 Teal Bldg - Testing/Commissioning HVAC (Start w. temp. Power) |  | 60d | 2012-04-07 | 2012-06-20 | XH00122205, XH000C10, X0300080, X0300008 FS+20d |  |  |  |  | 56.5d | 0d |  |  |  |  |  |  | XH00122210 |  | 0 | 0 | 934 |  | 12 | 200 | 200 | C | LND |  | X | H | XH20 | 1222 | H | 12 | X | hvac | LND | 1222 |  |  | SK1202 |  |  | ARMO |  |  |  |  | 2011-07-13 | 2011-09-08 |  |  |  |  |  |  |  |  |  |  |  |  |  |  |  |  |  |  |  |  |  |  |  |  |  |  |  |
| XH00122207 |  | CA12 Teal Bldg - HVAC ready for Heating | milestone | 0d | 2012-04-19 | 2012-04-19 | XH00122210 SS+10d |  |  |  |  | 291d | 107d |  |  |  |  |  | 3047 | XH00122207 |  | 0 | 0 | 934 |  | 12 | 200 | 200 | C | LND |  | X | H | XH00 | 1222 | H | 12 | X | hvac | LND | 1222 |  |  | SK1202 |  |  | ARMO |  |  |  |  | 2011-07-25 | 2011-07-25 |  |  |  |  |  |  |  |  |  |  |  |  |  |  |  |  |  |  |  |  |  |  |  |  |  |  |  |
|  | U | **Package Units** |  |  |  |  |  |  |  |  |  |  |  |  |  |  |  |  |  |  |  |  |  |  |  |  |  |  |  |  |  |  |  |  |  |  |  |  |  |  |  |  |  |  |  |  |  |  |  |  |  |  |  |  |  |  |  |  |  |  |  |  |  |  |  |  |  |  |  |  |  |  |  |  |  |  |  |  |  |  |
|  | B | **Mechanical - Stationary Equipment** |  |  | 2011-09-01 | 2011-11-22 |  |  |  |  |  |  |  |  |  |  |  |  |  |  |  |  |  |  |  |  |  |  |  |  |  |  |  |  |  |  |  |  |  |  |  |  |  |  |  |  |  |  |  |  |  |  |  |  |  |  |  |  |  |  |  |  |  |  |  |  |  |  |  |  |  |  |  |  |  |  |  |  |  |  |
| XB001222 |  | CA12 Teal Bldg - Install Static Eqpt | level of effort | 69.5d | 2011-09-01 | 2011-11-22 | MI-21106 A/B FF, MI-21107 A/B SS, MI-21108 A/B SS, MI-21108 A/B FF, MI-21106 A/B SS, MI-21107 A/B FF |  |  |  |  | 12.5d | 0d |  |  |  |  |  | 3 | XB001222 |  | 0 | 0 | 934 | XBB | 12 | 200 | 200 | C | LND |  | X | B | XB00 | 1222 | B | 12 | X | EQ | LND | 1222 |  | E-08-01-08 | SK1202 |  |  | VNZM |  |  | 2011-03-10 | 2011-05-10 |  |  | UDF_G1 | E-08-01-08 |  |  |  |  |  |  |  |  |  |  |  |  |  |  |  |  |  |  |  |  |  |  |  |  |  |
| MI-21107 A/B |  | UNLOADING ARMA |  | 12.5d | 2011-11-07 | 2011-11-21 | MI-21106 A/B, XN201222, P3A11S1 (other project) |  |  |  |  | 13d | 7.5d |  |  | Static equipment < 10t [100 h]; Static Equipment < 10 tons [1 t] | 4,000 |  | 100,00 | MI-21107 A/B |  | 100 | 0 |  |  | 12 |  |  |  |  | EQ | X | B |  | 1222 |  |  |  |  |  |  |  |  |  |  |  | VNZM |  |  |  |  |  |  |  |  | 1 | 500 | elev +3.00 | 2 KB 4420 | MI-21107 A/B | SK1222 | 2010-09-30 | 2010-11-30 | 2010-12-15 | 2011-01-10 | A11 UNLOADING ARMS (MI-21-/22107/8A/B) | SVT |  |  |  |  |  |  |  |  |  |  |  |  |  |
| MI-21108 A/B |  | UNLOADING ARMA |  | 13d | 2011-11-07 | 2011-11-22 | P3A11S1 (other project), MI-21106 A/B, XN201222 |  |  |  |  | 12.5d | 7d |  |  | Static Equipment < 10 tons [1 t]; Static equipment < 10t [100 h] | 4,000 |  | 100,00 | MI-21108 A/B |  | 100 | 0 |  |  | 12 |  |  |  |  | EQ | X | B |  | 1222 |  |  |  |  |  |  |  |  |  |  |  | VNZM |  |  |  |  |  |  |  |  | 1 | 500 | elev +3.00 | 2 KB 4420 | MI-21108 A/B | SK1222 | 2010-09-30 | 2010-11-30 | 2010-12-15 | 2011-01-10 | A11 UNLOADING ARMS (MI-21-/22107/8A/B) | SVT |  |  |  |  |  |  |  |  |  |  |  |  |  |
|  | M | **Mechanical - Rotating Equipment** |  |  | 2011-11-07 | 2011-11-30 |  |  |  |  |  |  |  |  |  |  |  |  |  |  |  |  |  |  |  |  |  |  |  |  |  |  |  |  |  |  |  |  |  |  |  |  |  |  |  |  |  |  |  |  |  |  |  |  |  |  |  |  |  |  |  |  |  |  |  |  |  |  |  |  |  |  |  |  |  |  |  |  |  |  |
| XM001222 |  | CA12 Teal Bldg - Install Rotating Eqpt | level of effort | 20d | 2011-11-07 | 2011-11-30 | P-21102 A/B FF, P-21102 A/B SS |  |  |  |  | -4.5d | 0d |  |  |  |  |  | 1 | XM001222 |  | 0 | 0 | 934 |  | 12 |  |  |  | LND |  | X | M | XM00 | 1222 | M | 12 | X | EQ | LND | 1222 |  | E-08-01-08 | SK1202 |  |  | VNZM |  |  | 2011-03-10 | 2011-05-10 |  |  | UDF_G1 | E-08-01-08 |  |  |  |  |  |  |  |  |  |  |  |  |  |  |  |  |  |  |  |  |  |  |  |  |  |
|  | R | **Piping** |  |  | 2011-07-23 | 2012-04-02 |  |  |  |  |  |  |  |  |  |  |  |  |  |  |  |  |  |  |  |  |  |  |  |  |  |  |  |  |  |  |  |  |  |  |  |  |  |  |  |  |  |  |  |  |  |  |  |  |  |  |  |  |  |  |  |  |  |  |  |  |  |  |  |  |  |  |  |  |  |  |  |  |  |  |
| XR201222 |  | CA12 Teal Bldg SK1202 - Piping Prefabrication |  | 86d | 2011-07-23 A | 2011-10-31 | ER491222 (other project) SS+18d |  | 56d |  |  | 20d | 28.5d |  |  | A/G piping prefabrication [420 Fpi]; A/G Piping (Prefab) [1575 h] | 1,529.91 |  | 1575,00 | XR201222 |  | 1575 | 0 | 934 |  | 12 | 200 | 200 | C | LND |  | X | R | XR20 | 1222 | R | 12 | X | PRP | LND | 1222 | 27.8. |  |  |  |  | VNZM |  |  |  |  |  |  |  |  |  |  |  |  |  |  |  |  |  |  |  |  | UDF_G4 | x |  |  |  |  |  |  |  |  |  |  |  |
| XR401222 |  | CA12 Teal Bldg SK1202 - Piping Installation |  | 70d | 2011-11-23 | 2012-02-20 | XR201222 FS-10d, P3J01AS (other project), P3J02DS (other project), P3J04CS1 (other project), P3J04IS (other project) FF+20d, XN601222, MI-21108 A/B FS-20d, P3J02AS (other project), P-21102 A/B FS-10d, MI-21107 A/B FS-20d, P3J02S (other project) FF+20d, MI-21106 A/B FS-20d, IMS-C-000190 FF, XN201222 |  |  |  |  | -8.5d | 0d |  |  | A/G piping field installation [510 Fpi]; Control & Shut-off valves [26 pcs]; Install Control & Shut-off Valves [136.5 h]; A/G Piping (Field) [3187.5 h] | 10,899.69 |  | 3324,00 | XR401222 |  | 3324 | 0 | 934 |  | 12 | 200 | 200 | C | LND |  | X | R | XR40 | 1222 | R | 12 | X | PI | LND | 1222 |  |  | SK1202 |  |  | VNZM |  |  | 2011-01-10 |  |  |  |  | E-06-03-03 |  |  |  |  |  |  |  |  |  |  |  |  |  |  | 2011-04-06 |  |  |  |  |  |  |  |  |  |  |
| XR601222 |  | CA12 Teal Bldg SK1202 - Piping Pressure Tests |  | 20d | 2012-02-27 | 2012-03-21 | XR605102 FF+20d, XR401222 FF+10d, X0300020 |  |  |  |  | 14d | 0d |  |  |  |  |  | 113 | XR601222 |  | 0 | 0 | 934 |  | 12 | 200 | 200 | C | LND |  | X | R | XR60 | 1222 | R | 12 | X | HY | LND | 1222 |  |  |  |  |  | VNZM |  |  |  |  |  |  |  | E-06-03-03 |  |  |  |  |  |  |  |  |  |  |  |  |  |  |  |  |  |  |  |  |  |  |  |  |  |
| XR801222 |  | CA12 Teal Bldg SK1202 - Piping Reinstatement |  | 20d | 2012-03-10 | 2012-04-02 | XR601222 FF+10d, IMS-C-000360 FF |  |  |  |  | 14d | 0d |  |  |  |  |  | 56 | XR801222 |  | 0 | 0 | 934 |  | 12 | 200 | 200 | C | LND |  | X | R | XR80 | 1222 | R | 12 | X | PI | LND | 1222 |  |  |  |  |  | VNZM |  |  |  | 2011-10-30 |  |  |  | E-06-03-03 |  |  |  |  |  |  |  |  |  |  |  |  |  |  |  | 2012-01-30 |  |  |  |  |  |  |  |  |  |
|  | E | **Electrical** |  |  | 2011-04-18 | 2012-08-17 |  |  |  |  |  |  |  |  |  |  |  |  |  |  |  |  |  |  |  |  |  |  |  |  |  |  |  |  |  |  |  |  |  |  |  |  |  |  |  |  |  |  |  |  |  |  |  |  |  |  |  |  |  |  |  |  |  |  |  |  |  |  |  |  |  |  |  |  |  |  |  |  |  |  |
| XC911222 |  | CA12 Teal Bldg - Install Earthing&Lightn.Sys_CIVIL |  | 114d | 2011-04-18 A | 2011-08-27 A | EE901222 (other project) | 100% |  | 2011-04-18 | 2011-08-31 |  |  |  | TB26 - V - Construct-Winter partly * | Grounding & Lightning [50 pcs]; Grounding & Lightning [562.5 h] | 22,500 | 22,500 | 562,50 | XC911222 |  | 562,5 | 450 | 934 |  | 12 | 200 | 200 | C | LND |  | X | C | XE91 | 1222 | C | 12 | X | EA | LND | 1222 | 27.8. |  |  |  |  | MO11 |  |  |  |  |  |  |  |  |  |  |  |  |  |  |  |  |  |  |  |  | UDF_G4 | actual finish |  |  |  |  |  |  |  |  |  |  |  |
| XE911225 |  | CA12 Teal Bldg - Install Earthing&Lightn.Sys_E/I |  | 20d | 2011-11-30 | 2012-01-24 | XN201222, MI-21106 A/B, MI-21107 A/B, MI-21108 A/B, P-21102 A/B |  |  |  |  | 112.5d | 175d |  | TB26 - V - Construct-Winter partly * |  |  |  | 55 | XE911225 |  | 0 | 0 | 934 |  | 12 | 200 | 200 | C | LND |  | X | E | XE91 | 1222 | E | 12 | X | EA | LND | 1222 |  |  |  |  |  | URMA |  |  | 2011-05-10 | 2011-12-10 |  |  |  | E-16-07-03 |  |  |  |  |  |  |  |  |  |  |  |  | UDF_G3 |  |  |  | 2012-05-10 | 2011-07-11 |  |  |  |  |  |  |  |
| XE401222 |  | CA12 Teal Bldg - Install CableTrays |  | 30d | 2012-01-10 | 2012-02-14 | XN801222, XR401222 SS+35d, EE46122210 (other project), XN601222 |  |  |  |  | 6.5d | 0d |  |  | Cable trays/conduits [180 m]; Cable trays [540 h] | 21,600 |  | 540,00 | XE401222 | x | 540 | 0 | 934 |  | 12 | 200 | 200 | C | LND |  | X | E | XE40 | 1222 | E | 12 | X | EL | LND | 1222 |  |  |  | m |  | URMA |  |  | 2011-05-10 | 2011-08-20 |  |  |  | E-15-01-09 |  |  |  |  |  |  |  |  |  |  |  |  | UDF_G3 |  |  |  | 2011-12-20 | 2011-07-20 | 300 | 2011-07-18 | 2011-09-01 |  |  |  |  |
| XE341222 |  | CA12 Teal Bldg - Install Local Operation Panels |  | 20d | 2012-02-14 | 2012-03-10 | XE401222, EE46122210 (other project), XR401222 SS+35d, MI-21106 A/B, MI-21107 A/B, MI-21108 A/B, P-21102 A/B |  |  |  |  | 20.5d | 76d |  |  | Field Panels [3 pcs]; Field panels [60 h] | 2,400 |  | 60,00 | XE341222 |  | 60 | 0 | 934 |  | 12 | 200 | 200 | C | LND |  | X | E | XE34 | 1222 | E | 12 | X | EL | LND | 1222 |  |  |  |  |  | URMA |  |  | 2011-05-10 | 2011-12-10 |  |  |  | E-16-07-03 |  |  |  |  |  |  |  |  |  |  |  |  | UDF_G3 |  |  |  | 2012-05-10 | 2011-07-11 |  |  |  |  |  |  |  |
| XE801222 |  | CA12 Teal Bldg - Install Heat Tracing |  | 30d | 2012-02-27 | 2012-04-02 | XE800C00 SS, P3E19S (other project), E3E1950 (other project), XW501222 FF+20d, XR401222, P-21102 A/B, XR601222 FF+10d |  |  |  |  | 40d | 0d |  |  | Electrical Heat Tracing [700 m]; Electrical heat tracing [350 h] | 14,000 |  | 350,00 | XE801222 |  | 350 | 0 | 934 |  | 12 | 200 | 200 | C | LND |  | X | E | XE80 | 1222 | E | 12 | X | HT | LND | 1222 | 27.8. |  |  |  |  | URMA |  |  | 2011-06-20 | 2012-03-20 |  |  |  | E-16-04-01 |  |  |  |  |  |  |  |  |  |  |  |  | UDF_G3 |  |  |  | 2012-06-30 | 2011-09-15 |  |  |  | 005 | to be installed later |  |  |
| XE701222 |  | CA12 Teal Bldg - Install Lighting & Small Power |  | 40d | 2012-03-03 | 2012-04-20 | XC401222, XJ421222, EE761222 (other project), XE401222, P3E09S (other project), XP341610 FS+50d |  |  |  |  | 58.5d | 39d |  |  | Cable Pulling [500 m]; Lighting illuminates [50 pcs]; Lighting (iluminates) [500 h]; Cable pulling [250 h] | 30,000 |  | 750,00 | XE701222 |  | 750 | 0 | 934 |  | 12 | 200 | 200 | C | LND |  | X | E | XE70 | 1222 | E | 12 | X | EL | LND | 1222 |  |  |  |  |  | URMA | x |  | 2011-05-10 | 2012-01-31 |  |  |  | E-16-03-01 |  |  |  |  |  |  |  |  |  |  |  |  |  |  |  |  | 2012-05-10 | 2011-08-15 |  |  |  |  |  |  |  |
| XE921222 |  | CA12 Teal Bldg - Install Fire Detection System |  | 60d | 2012-06-07 | 2012-08-17 | XJ421222, XH00122205, XE701222, XC501222 |  |  |  |  | 191d | 0d |  |  | Fire Detection System; Fire detection system |  |  | 0,00 | XE921222 | x | 0 | 0 | 934 |  | 12 | 200 | 200 | C | UIO |  | X | E | XE92 | 1222 | E | 12 | X | FGDS | LND | 1222 |  |  |  |  |  |  | x |  | 2011-05-10 | 2011-12-10 |  |  |  | E-16-07-03 |  |  |  |  |  |  |  |  |  |  |  |  |  |  |  |  |  |  |  |  |  |  |  | 2012-02-13 | 2012-07-09 |
| XE961222 |  | CA12 Teal Bldg - Install Communication System |  | 60d | 2012-06-07 | 2012-08-17 | XC501222, XH00122205, E3E1350 (other project), XJ421222, XE921222 SS, XE701222 |  |  |  |  | 192d |  |  | TB26 - V - Construct-Winter partly * | Communication System |  |  | 0,00 | XE961222 | x | 0 | 0 | 934 |  | 12 | 200 | 200 | C | LND |  | X | E | XE96 | 1222 | E | 12 | X | CS | LND | 1222 |  |  |  |  |  |  | x |  | 2011-05-10 | 2011-12-10 |  |  |  | E-16-07-03 |  |  |  |  |  |  |  |  |  |  |  |  |  |  |  |  |  |  |  |  |  |  |  | 2012-02-13 | 2012-07-09 |
| XE501222 |  | CA12 Teal Bldg - Cable Pulling Electric |  | 30d | 2012-06-09 | 2012-07-16 | XE401222, XE500C01, P3E15CS (other project), P3E15AS (other project), P3E15BS (other project), XE501204 SS, EE561222 (other project), XE505401 SS+12d, XE505102 SS+10d, XE501201 SS |  |  |  |  | -55.5d | 0d |  | TB26 - V - Construct-Winter partly * | Cable Pulling [2200 m]; Cable pulling [1100 h] | 44,000 |  | 1100,00 | XE501222 |  | 1100 | 0 | 934 |  | 12 | 200 | 200 | C | LND |  | X | E | XE50 | 1222 | E | 12 | X | EL | LND | 1222 |  |  |  | m |  | URMA |  |  | 2011-05-20 | 2012-02-10 |  |  |  | E-16-01-01 |  |  |  |  |  |  |  |  |  |  |  |  | UDF_G3 |  |  |  | 2012-07-01 | 2011-10-01 | 2300 | 2011-09-02 | 2011-11-15 |  |  |  |  |
| XE601222 |  | CA12 Teal Bldg - Cable Termination & Testing |  | 50d | 2012-06-09 | 2012-08-08 | XE501222 FF+20d, XE341222, MI-21106 A/B, MI-21107 A/B, MI-21108 A/B, P-21102 A/B |  |  |  |  | -55.5d | 15d |  | TB26 - V - Construct-Winter partly * | Cable connecting [20 pcs]; Cable connecting [50 h] | 2,000 |  | 50,00 | XE601222 |  | 50 | 0 | 934 |  | 12 | 200 | 200 | C | LND |  | X | E | XE60 | 1222 | E | 12 | X | ET | LND | 1222 |  |  |  |  |  | URMA |  |  | 2011-04-20 | 2011-11-30 |  |  |  | E-16-02-01 |  |  |  |  |  |  |  |  |  |  |  |  | UDF_G3 |  |  |  | 2012-08-14 | 2011-12-10 |  |  |  |  |  |  |  |

Notes:
- XN711202: Scope: 09.02.2011: weight: 6 ton - Dec 1 ton; Jan / 14 ton; Feb 1 ton
- XH00122205: Current Status: 110304 Delete PRED Finishing Works XC501222
- XH00122210: Current Status: 21.01.2011 - Siegel - Vorgдnger zur IBN HVAC / Condensat, LP-Dampf, Kьhlwasser von FF + 30 Tage Lag auf FS + 0 geдndert!
- XB001222: Current Status: 110304 (WL) Add PRED XN201222 Install Prim Steel / Eqpt Platforms / 110304 (WL) Delete PRED XH00122205 Installation HVAC / 17.01.2011 (Siegel): verschiebung ergibt sich auf Grund von Verschiebungen / des Civil-Teils: "Concrete Works Building" Endtermin vom 18-Jan-11 auf den / 01-Mar-11.
- XM001222: Current Status: 110304 (WL) Add PRED XN201222 Install Prim Steel / Eqpt Platforms / 110304 (WL) Delete PRED XH00122205 Installation HVAC / 17.01.2011 (Siegel): verschiebung ergibt sich auf Grund von Verschiebungen / des Civil-Teils: "Concrete Works Building" Endtermin vom 18-Jan-11 auf den / 01-Mar-11.
- XR401222: P3 Activity Log Info: Start with Fire Water System / Current Status: 110304 (WL) Delete PRED XN801222 Cladding Works Walls/Roof / 110304 (WL) Add PRED XN201222 Install Prim Steel / Eqpt Platforms
- XE921222: Scope: CA12 Polymerization Line 1 / FDS - 49 external sensors / GDS - 29 external sensors / DS + SAME
- XE961222: Scope: CA12 Polymerization Line 1 / FDS - 49 external sensors / GDS - 29 external sensors / DS + SAME

| ID | WBS | Activity | Type | Duration | Start | Finish | Predecessors | Remaining | Total float | Free float | Constraint | Calendar | Resources | Cost | TB26 Ressource Budget | UDF_CONTRACT START DATE | UDF_CONTRACT FINISH DATE | UDF_CONTRACT ITEM | UDF_CONTRACT INDICATOR | UDF_CONTRACT FINISH DATE REV1 | UDF_CONTRACT START DATE REV1 | UDF_SAVE ACT ID | UDF_BUDGETED LABOR UNIT | UDF_ACTUAL LABOR UNIT | UDF_COMMENTS_0827 | Department | Constr. Area | PMT-Area | PMT-Schedule Org | PMT-Phase | PMT-Respons. | WBS Phase | WBS Discipline | WBS Type of Work | WBS Objects | Russia WBS Discipline (Russia) | Russia Construction Area | Russia WBS Phase | IMS | UPT | Russia WBS Objects | Subcontractor | Filter | TB26 Semantics | TB26 Material Res Values | UDF_ELECTRICAL START | UDF_ELECTRICAL FINISH | UDF_CHECK BASELINE | UDF_PENALIZED FINISH | UDF_SELECT UPDATE PROGRESS | UDF_CHECK RESOURCE DATES | Comments | UDF_Weight (ton) | WEIGHT | UDF_LEVEL | UDF_PO No | UDF_TAG No | UDF_Object No | UDF_DELIVERY DATE PO | UDF_DELIVERY DATE DISPATCH PLANNED | UDF_DELIVERY DATE TO SITE PLANNED | UDF_DELIVERY DATE SITE NEED DATE | UDF_SHIPMENT No | UDF_PACKAGE | UDF_SUPPLIER | Zeigen/n. Zeigen | UDF_COMMENTS | Drawing Indicator | Type of Work |
| --- | --- | --- | --- | --- | --- | --- | --- | --- | --- | --- | --- | --- | --- | --- | --- | --- | --- | --- | --- | --- | --- | --- | --- | --- | --- | --- | --- | --- | --- | --- | --- | --- | --- | --- | --- | --- | --- | --- | --- | --- | --- | --- | --- | --- | --- | --- | --- | --- | --- | --- | --- | --- | --- | --- | --- | --- | --- | --- | --- | --- | --- | --- | --- | --- | --- | --- | --- | --- | --- |
|  | J | **Instrumentation** |  |  | 2012-01-10 | 2012-11-16 |  |  |  |  |  |  |  |  |  |  |  |  |  |  |  |  |  |  |  |  |  |  |  |  |  |  |  |  |  |  |  |  |  |  |  |  |  |  |  |  |  |  |  |  |  |  |  |  |  |  |  |  |  |  |  |  |  |  |  |  |  |  |  |
| XJ321222 |  | CA12 Teal Bldg - Install Junction Boxes |  | 30d | 2012-01-10 | 2012-02-14 | P3J06FS (other project), EJ321222 (other project), P3J06ES (other project) FS+14d, XR401222 SS+35d, MI-21106 A/B, MI-21107 A/B, MI-21108 A/B, P-21102 A/B |  | -8.5d | 0d |  |  | Junction Boxes/Cabinets/Panels [23 pcs]; Install Junction Boxes/ Cabinets/ Panels [575 h] | 23,000 | 575,00 | 2011-05-10 | 2012-03-01 | E-17-04-03 | UDF_G3 | 2012-08-15 | 2011-07-25 | XJ321222 | 575 | 0 | to be installed later | 934 | 12 | 200 | 200 | C | LND | X | J | XJ32 | 1222 | J | 12 | X | IN | LND | 1222 | URMA |  |  |  |  |  |  |  |  |  |  |  |  |  |  |  |  |  |  |  |  |  |  |  |  |  |  |  |
| XJ421222 |  | CA12 Teal Bldg - Install Secondary Cable Trays |  | 30d | 2012-01-27 | 2012-03-03 | EJ46122210 (other project), XE401222 FF, XJ321222 FF+15d, XR401222 SS+35d, MI-21106 A/B, MI-21107 A/B, MI-21108 A/B, P-21102 A/B |  | -8.5d | 0d |  |  | Secondary cable trays [120 m]; Install secondary cable trays [450 h] | 18,000 | 450,00 | 2011-05-10 | 2011-08-20 | E-15-01-09 |  | 2011-12-20 | 2011-07-20 | XJ421222 | 450 | 0 | to be installed later | 934 | 12 | 200 | 200 | C | LND | X | J | XJ42 | 1222 | J | 12 | X | IN | LND | 1222 | URMA | x | m | 220 | 2011-07-18 | 2011-09-01 | x |  |  |  |  |  |  |  |  |  |  |  |  |  |  |  |  |  |  |  |  |  |
| XJ301222 |  | CA12 Teal Bldg - Install Field Instruments |  | 40d | 2012-02-14 | 2012-04-02 | P3J05S (other project), XR801222 FF, P3J12AS (other project), P3J04AS (other project), EJ361222 (other project), P3J04BS (other project), XR401222 SS+35d, MI-21106 A/B, MI-21107 A/B, MI-21108 A/B, P-21102 A/B |  | 14d | 0d |  |  | Field Instruments [128 pcs]; Install field instruments [704 h] | 28,160 | 704,00 | 2011-05-10 | 2012-03-01 | E-17-04-03 | UDF_G3 | 2012-08-15 | 2011-07-25 | XJ301222 | 704 | 0 | to be installed later | 934 | 12 | 200 | 200 | C | LND | X | J | XJ30 | 1222 | J | 12 | X | IN | LND | 1222 | URMA |  |  |  |  |  |  |  |  |  |  |  |  |  |  |  |  |  |  |  |  |  |  |  |  |  |  |  |
| XJ441222 |  | CA12 Teal Bldg - Install Conduits to Instrm |  | 40d | 2012-03-05 | 2012-04-25 | XJ321222, MI-21106 A/B, MI-21107 A/B, MI-21108 A/B, P-21102 A/B, XR401222 SS+35d, XE401222, XJ421222 |  | -6d | 0d |  | TB26 - V - Construct-Winter partly * |  |  |  | 2011-05-10 | 2012-03-01 | E-17-04-03 |  | 2012-08-15 | 2011-07-25 | XJ441222 | 0 | 0 | to be installed later | 934 | 12 | 200 | 200 | C | LND | X | J | XJ44 | 1222 | J | 12 | X | IN | LND | 1222 | URMA |  |  |  |  |  |  |  |  |  |  |  |  |  |  |  |  |  |  |  |  |  |  |  |  |  |  |  |
| XJ541222 |  | CA12 Teal Bldg - Pulling Singlecore Cables |  | 40d | 2012-03-20 | 2012-05-09 | XJ301222 FF+20d, XE500C01, EJ801222 (other project), XJ441222 SS+10d, XJ421222 |  | 29d | 35d |  | TB26 - V - Construct-Winter partly * | Singlecore cables [11000 m]; Pull singlecore cables [8250 h] | 330,000 | 8250,00 | 2011-05-10 | 2012-03-01 | E-17-04-03 |  | 2012-08-15 | 2011-07-25 | XJ541222 | 8250 | 0 |  | 934 | 12 | 200 | 200 | C | LND | X | J | XJ54 | 1222 | J | 12 | X | IN | LND | 1222 | URMA |  | m | 10567 | 2011-11-08 | 2011-12-23 |  |  |  |  |  |  |  |  |  |  |  |  |  |  |  |  |  |  |  |  |  |  |
| XJ701222 |  | CA12 Teal Bldg - Instrument Tubing |  | 20d | 2012-04-03 | 2012-04-25 | XJ301222 FF+20d, XR401222 |  | 14d | 20d |  |  |  |  |  | 2011-05-10 | 2012-03-01 | E-17-04-03 |  | 2012-08-15 | 2011-07-25 | XJ701222 | 0 | 0 |  | 934 | 12 | 200 | 200 | C | LND | X | J | XJ70 | 1222 | J | 12 | X | IN | LND | 1222 | URMA |  |  |  |  |  |  |  |  |  |  |  |  |  |  |  |  |  |  |  |  |  |  |  |  |  |  |  |
| XJ391222 |  | CA12 Teal Bldg - Install Earthing Field Eqpt |  | 20d | 2012-04-26 | 2012-05-21 | XJ301222 FF+10d, XJ441222, XJ421222 |  | -6d | 0d |  |  |  |  |  | 2011-05-10 | 2012-03-01 | E-17-04-03 | UDF_G3 | 2012-08-15 | 2011-07-25 | XJ391222 | 0 | 0 |  | 934 | 12 | 200 | 200 | C | LND | X | J | XJ39 | 1222 | J | 12 | X | IN | LND | 1222 | URMA |  |  |  |  |  |  |  |  |  |  |  |  |  |  |  |  |  |  |  |  |  |  |  |  |  |  |  |
| XJ641222 |  | CA12 Teal Bldg - Termin Singlecore Cables |  | 40d | 2012-05-22 | 2012-07-07 | XJ541222 FF+15d, XJ301222, XJ321222, XJ391222, XJ701222 |  | -6d | 56.5d |  | TB26 - V - Construct-Winter partly * | Termination Field [705 mhr]; Termination field [705 h] | 70,500 | 705,00 | 2011-05-10 | 2012-03-01 | E-17-04-03 |  | 2012-08-15 | 2011-07-25 | XJ641222 | 705 | 0 |  | 934 | 12 | 200 | 200 | C | LND | X | J | XJ64 | 1222 | J | 12 | X | IN | LND | 1222 | URMA |  |  |  |  |  |  |  |  |  |  |  |  |  |  |  |  |  |  |  |  |  |  |  |  |  |  |  |
| XJ521222 |  | CA12 Teal Bldg - Pulling Multicore Cables |  | 40d | 2012-06-13 | 2012-07-30 | XJ521204 SS+10d, XJ321222 SS+20d, XE500C01, XE401222, XJ525401 SS+15d, XJ525102 SS+12d |  | -7.5d | 0d |  | TB26 - V - Construct-Winter partly * | Multicore cables [4000 m]; Pull multicore cables [2000 h] | 80,000 | 2000,00 | 2011-05-20 | 2012-03-10 | E-17-01-01 |  | 2012-06-16 | 2011-11-01 | XJ521222 | 2000 | 0 | to be checked | 934 | 12 | 200 | 200 | C | LND | X | J | XJ52 | 1222 | J | 12 | X | IN | LND | 1222 | URMA |  | m | 2900 | 2011-09-02 | 2011-10-18 |  |  |  |  |  |  |  |  |  |  |  |  |  |  |  |  |  |  |  |  |  |  |
| XJ621222 |  | CA12 Teal Bldg - Termin Multicore Cables |  | 40d | 2012-06-25 | 2012-08-10 | XJ521222 FF+10d, XJ321222 |  | -7.5d | 63d |  |  | Termination Field [705 mhr]; Termination field [705 h] | 70,500 | 705,00 | 2011-05-20 | 2012-03-10 | E-17-01-01 |  | 2012-06-16 | 2011-11-01 | XJ621222 | 705 | 0 | to be checked | 934 | 12 | 200 | 200 | C | LND | X | J | XJ62 | 1222 | J | 12 | X | IN | LND | 1222 | URMA |  |  |  |  |  |  |  |  |  |  |  |  |  |  |  |  |  |  |  |  |  |  |  |  |  |  |  |
| XJ801222 |  | CA12 Teal Bldg - Inspections/ Mech. Acceptance/ Loop Checks |  | 70d | 2012-08-25 | 2012-11-16 | XJ641222 FF+20d, XE601222, X030410030, X3J120, EJ801222 (other project), XJ701222 SS, X0300015, XJ391222 SS+10d, XJ621222 FF+20d |  | -70.5d | 12d |  | TB26 - V - Construct-Winter partly * | Loop Checks [350 pcs]; Loop checks [1750 h] | 70,000 | 1750,00 | 2011-06-10 | 2012-04-30 | E-17-02-01 |  | 2012-08-18 | 2012-03-01 | XJ801222 | 1750 | 0 |  | 934 | 12 | 200 | 200 | C | LND | X | J | XJ80 | 1222 | J | 12 | X | LT | LND | 1222 | URMA |  |  |  |  |  |  | 2012-08-18 |  |  |  |  |  |  |  |  |  |  |  |  |  |  |  |  |  |  |  |  |
|  | S | **Safety & Environment** |  |  |  |  |  |  |  |  |  |  |  |  |  |  |  |  |  |  |  |  |  |  |  |  |  |  |  |  |  |  |  |  |  |  |  |  |  |  |  |  |  |  |  |  |  |  |  |  |  |  |  |  |  |  |  |  |  |  |  |  |  |  |  |  |  |  |  |
|  | W | **Painting** |  |  | 2011-08-15 | 2011-09-14 |  |  |  |  |  |  |  |  |  |  |  |  |  |  |  |  |  |  |  |  |  |  |  |  |  |  |  |  |  |  |  |  |  |  |  |  |  |  |  |  |  |  |  |  |  |  |  |  |  |  |  |  |  |  |  |  |  |  |  |  |  |  |  |
| XW501222 |  | CA12 Teal Bldg - Surf.Protection Piping |  | 27d | 2011-08-15 A | 2011-09-14 | XR201222 SS | 16d | 183d | 143d |  |  | Piping painting [142 sqm]; Piping painting [355 h] | 220.25 | 355,00 |  |  |  |  |  |  | XW501222 | 355 | 0 |  | 934 | 12 | 200 | 200 | C | LND | X | W | XW50 | 1222 | W | 12 | X | PA | LND | 1222 | VNZM |  |  |  |  |  |  |  | 27.8. | x |  |  |  |  |  |  |  |  |  |  |  |  |  |  |  |  |  |  |
|  | V | **Insulation** |  |  | 2012-03-22 | 2012-07-12 |  |  |  |  |  |  |  |  |  |  |  |  |  |  |  |  |  |  |  |  |  |  |  |  |  |  |  |  |  |  |  |  |  |  |  |  |  |  |  |  |  |  |  |  |  |  |  |  |  |  |  |  |  |  |  |  |  |  |  |  |  |  |  |
| XV301222 |  | CA12 Teal Bldg - Insulation Equipment |  | 80d | 2012-03-22 | 2012-06-28 | XE801222 SS+20d |  | 37d | 0d |  | TB26 - V - Construct-Winter partly * | Equipment insulation [75 sqm]; Equipment insulation [938 h] | 155.21 | 938,00 |  | 2012-03-30 | E-13-03 |  |  |  | XV301222 | 938 | 0 |  | 934 | 12 | 200 | 200 | C | LND | X | V | XV30 | 1222 | V | 12 | X | INS | LND | 1222 | VNZM |  |  |  |  |  |  |  |  |  |  |  |  |  |  |  |  |  |  |  |  |  |  |  |  |  |  |  |
| XV501222 |  | CA12 Teal Bldg - Insulation Piping |  | 70d | 2012-04-19 | 2012-07-12 | XE801222 FF+20d, XV301222 FF+12d, XR601222 SS+20d |  | 37d | 119.5d |  | TB26 - V - Construct-Winter partly * | Piping insulation [150 sqm]; Piping insulation [1125 h] | 626.75 | 1125,00 |  | 2012-04-30 | E-13-01 |  |  |  | XV501222 | 1125 | 0 |  | 934 | 12 | 200 | 200 | C | LND | X | V | XV50 | 1222 | V | 12 | X | INS | LND | 1222 | VNZM |  |  |  |  |  |  |  |  |  |  |  |  |  |  |  |  |  |  |  |  |  |  |  |  |  |  |  |
|  | 30 | **CA12 - Other Ground Based Eqpt** |  |  | 2010-08-19 | 2012-10-23 |  |  |  |  |  |  |  |  |  |  |  |  |  |  |  |  |  |  |  |  |  |  |  |  |  |  |  |  |  |  |  |  |  |  |  |  |  |  |  |  |  |  |  |  |  |  |  |  |  |  |  |  |  |  |  |  |  |  |  |  |  |  |  |
|  | C | **Civil Work** |  |  | 2011-10-13 | 2011-11-07 |  |  |  |  |  |  |  |  |  |  |  |  |  |  |  |  |  |  |  |  |  |  |  |  |  |  |  |  |  |  |  |  |  |  |  |  |  |  |  |  |  |  |  |  |  |  |  |  |  |  |  |  |  |  |  |  |  |  |  |  |  |  |  |
| XC201230 |  | CA12 OthGrBasedEqpt SK1210 - Concrete Works Fdtn |  | 20d | 2011-10-13 | 2011-11-07 | XC151200, XC20120105 FS+25d, EC281230 (other project) FS+10d, XC301200 SS+40d, XC191205 SS+20d |  | 0d |  | mandatory finish 2011-11-07 | TB26 - V - Construct-Winter partly * | Concrete works [100 cbm]; Concrete works [3000 h] |  | 3000,00 |  |  |  |  |  |  | XC201230 | 3000 | 0 |  | 934 | 12 | 200 | 200 | C | MO03 | X | C | XC20 | 1230 | C | 12 | X | mis | LND | 1230 | MO11 | 1 |  |  |  |  |  |  |  |  | !!!!! |  |  |  |  |  |  |  |  |  |  |  |  |  |  |  |  |  |
|  | M | **Mechanical - Rotating Equipment** |  |  | 2011-11-08 | 2011-11-18 |  |  |  |  |  |  |  |  |  |  |  |  |  |  |  |  |  |  |  |  |  |  |  |  |  |  |  |  |  |  |  |  |  |  |  |  |  |  |  |  |  |  |  |  |  |  |  |  |  |  |  |  |  |  |  |  |  |  |  |  |  |  |  |
| P-21201A/B |  | REACTOR QUENCH LIQUID PUMPS |  | 10d | 2011-11-08 | 2011-11-18 | HO-21206, XC201230, XN201201u, ER291200 (other project), XM001230 FF, XC911230, P3M05S1 (other project), HO-21205, XM001230 SS |  | -45d | 0d |  |  | Rotating Equipment (w/ lube oil unit) [12.4 t]; Rotating equipment (w/ lube oil unit) [1013.25 h] | 49,600 | 1013,25 |  |  |  |  |  |  | P-21201A/B | 1013,25 | 0 |  |  | 12 |  |  |  |  | X | M |  | 1230 |  |  |  |  |  |  | VNZM |  |  |  |  |  |  |  |  |  |  | 11,58 | 5790 | concrete +0.00 | 2 PA 6550 / 4 | P-21201A/B | SK1230 | 2010-09-21 | 2010-11-26 | 2010-12-15 | 2011-01-20 | 1231 | M05 REACTOR QUENCH LIQUID PUMPS (P-21-/22201A/B) | KSB | EQ |  |  |  |
| P-21203 |  | REACTOR TEPID WATER PUMP |  | 10d | 2011-11-08 | 2011-11-18 | XM001230 FF, XN201201l FS+5d, XM001230 SS, XC201230, P3M06S1 (other project), ER291200 (other project), XC911230 |  | -3d | 0d |  |  | Rotating Equipment (w/ lube oil unit) [3.75 t]; Rotating equipment (w/ lube oil unit) [328.12 h] | 14,996 | 328,13 |  |  |  |  |  |  | P-21203 | 328,12 | 0 |  |  | 12 |  |  |  |  | X | M |  | 1230 |  |  |  |  |  |  | VNZM |  |  |  |  |  |  |  |  |  |  | 3,749 | 3749 | concrete +0.00 | 2 PA 6540 / 5 | P-21203 | SK1230 | 2010-09-25 | 2010-11-26 | 2010-12-15 | 2011-01-20 | 1232 | M06 REACTOR TEPID WATER PUMPS (P-21-/22203) | KSB | EQ | between BB Compressor and RG Compressor |  |  |
| XM001230 |  | CA12 OthGrBasedEqpt - Install Rotating Eqpt | level of effort | 10d | 2011-11-08 | 2011-11-18 |  |  | -3d | 0d |  |  |  |  | 16 | 2011-03-10 | 2011-05-10 | E-08-01-08 |  |  |  | XM001230 | 0 | 0 |  | 934 | 12 | 200 | 200 | C | LND | X | M | XM00 | 1230 | M | 12 | X | EQ | LND | 1230 | VNZM |  |  |  |  |  |  |  |  |  | E-08-01-08 |  |  |  |  |  |  |  |  |  |  |  |  |  |  |  | UDF_G2 | XBB |

Notes:
- XW501222: P3 Activity Log Info: Clarification Surface Protection during Prefab

| ID | WBS | Activity | Duration | Start | Finish | Predecessors | Complete | Remaining | Total float | Free float | Calendar | Resources | Cost | Actual cost | TB26 Ressource Budget | UDF_CONTRACT INDICATOR | UDF_SELECT UPDATE PROGRESS | UDF_SAVE ACT ID | UDF_BUDGETED LABOR UNIT | UDF_ACTUAL LABOR UNIT | UDF_CHECK RESOURCE DATES | Department | Constr. Area | PMT-Area | PMT-Schedule Org | PMT-Phase | PMT-Respons. | WBS Phase | WBS Discipline | WBS Type of Work | WBS Objects | Russia WBS Discipline (Russia) | Russia Construction Area | Russia WBS Phase | IMS | UPT | Russia WBS Objects | Subcontractor | UDF_CONTRACT START DATE | UDF_CONTRACT ITEM | UDF_PLANNED START | UDF_CONTRACT FINISH DATE | UDF_PLANNED FINISH | UDF_CONTRACT FINISH DATE REV1 | UDF_CONTRACT START DATE REV1 | TB26 Semantics | TB26 Material Res Values | UDF_ELECTRICAL START | UDF_ELECTRICAL FINISH | UDF_CHECK BASELINE | UDF_COMMENTS_0827 | UDF_Vendor Representatives | UDF_PENALIZED FINISH |
| --- | --- | --- | --- | --- | --- | --- | --- | --- | --- | --- | --- | --- | --- | --- | --- | --- | --- | --- | --- | --- | --- | --- | --- | --- | --- | --- | --- | --- | --- | --- | --- | --- | --- | --- | --- | --- | --- | --- | --- | --- | --- | --- | --- | --- | --- | --- | --- | --- | --- | --- | --- | --- | --- |
|  | B | **Mechanical - Stationary Equipment** |  |  |  |  |  |  |  |  |  |  |  |  |  |  |  |  |  |  |  |  |  |  |  |  |  |  |  |  |  |  |  |  |  |  |  |  |  |  |  |  |  |  |  |  |  |  |  |  |  |  |  |
|  | R | **Piping** |  | 2011-07-19 | 2012-04-02 |  |  |  |  |  |  |  |  |  |  |  |  |  |  |  |  |  |  |  |  |  |  |  |  |  |  |  |  |  |  |  |  |  |  |  |  |  |  |  |  |  |  |  |  |  |  |  |  |
| XR201230 |  | CA12 OthGrBasedEqpt SK1210 - Piping Prefabrication | 115d | 2011-07-19 A | 2011-11-30 | ER491230 (other project) SS+18d |  | 81d | 58d | 403.5d |  | A/G piping prefabrication [1400 Fpi]; A/G Piping (Prefab) [5250 h] | 5,096.01 |  | 5250,00 | UDF_G4 | 27.8. | XR201230 | 5250 | 0 | x | 934 | 12 | 200 | 200 | C | LND | X | R | XR20 | 1230 | R | 12 | X | PRP | LND | 1230 | VNZM |  |  |  |  |  |  |  |  |  |  |  |  |  |  |  |
| XR401230 |  | CA12 OthGrBasedEqpt SK1210 - Piping Installation | 50d | 2011-11-08 | 2012-01-11 | P3J02S (other project) FF+20d, XR201230 SS+25d, P3R04S1 (other project) FF+20d, P3J02DS (other project) FF+20d, P3J04IS (other project) FF+20d, P3J04CS1 (other project), P-21203 SS, P-21201A/B SS, P3R07AS1 (other project), P3R03AS1 (other project) FF+20d, P3J02AS (other project) |  |  | -3d | 0d |  | A/G piping field installation [1700 Fpi]; Control & Shut-off valves [54 pcs]; Install Control & Shut-off Valves [283.5 h]; A/G Piping (Field) [10625 h] | 29,462.44 |  | 10908,50 |  |  | XR401230 | 10908,5 | 0 |  | 934 | 12 | 200 | 200 | C | LND | X | R | XR40 | 1230 | R | 12 | X | PI | LND | 1230 | VNZM | 2011-01-10 | E-06-03-03 | 2011-04-06 |  |  |  |  |  |  |  |  |  |  |  |  |
| XR601230 |  | CA12 OthGrBasedEqpt SK1210 - Piping Pressure Tests | 40d | 2012-02-02 | 2012-03-21 | XR605102 FF+20d, XR401230 |  |  | 14d | 0d |  |  |  |  | 375 |  |  | XR601230 | 0 | 0 |  | 934 | 12 | 200 | 200 | C | LND | X | R | XR60 | 1230 | R | 12 | X | HY | LND | 1230 | VNZM |  | E-06-03-03 |  |  |  |  |  |  |  |  |  |  |  |  |  |
| XR801230 |  | CA12 OthGrBasedEqpt SK1210 - Piping Reinstatement | 40d | 2012-02-14 | 2012-04-02 | XR601230 FF+10d, IMS-C-000360 FF |  |  | 14d | 0d |  |  |  |  | 188 |  |  | XR801230 | 0 | 0 |  | 934 | 12 | 200 | 200 | C | LND | X | R | XR80 | 1230 | R | 12 | X | PI | LND | 1230 | VNZM |  | E-06-03-03 |  | 2011-10-30 | 2012-01-30 |  |  |  |  |  |  |  |  |  |  |
|  | E | **Electrical** |  | 2010-08-19 | 2012-08-08 |  |  |  |  |  |  |  |  |  |  |  |  |  |  |  |  |  |  |  |  |  |  |  |  |  |  |  |  |  |  |  |  |  |  |  |  |  |  |  |  |  |  |  |  |  |  |  |  |
| XC911230 |  | CA12 OthGrBasedEqpt - Install Earthing&LightnSys_CIVIL | 43d | 2010-08-19 A | 2010-10-07 A | XC201230 FF+10d, EE901230 (other project) | 100% |  |  |  |  | Grounding & Lightning [50 pcs]; Grounding & Lightning [562.5 h] | 22,500 | 22,500 | 562,50 |  |  | XC911230 | 562,5 | 562,5 |  | 934 | 12 | 200 | 200 | C | LND | X | C | XE91 | 1230 | C | 12 | X | EA | LND | 1230 | MO11 |  |  |  |  |  |  |  |  |  |  |  |  |  |  |  |
| XE911235 |  | CA12 OthGrBasedEqpt - Install Earthing&LightnSys_E/I | 10d | 2011-11-19 | 2011-11-30 | P-21201A/B, P-21203 |  |  | 172d | 234.5d |  |  |  |  | 55 | UDF_G3 |  | XE911235 | 0 | 0 |  | 934 | 12 | 200 | 200 | C | LND | X | E | XE91 | 1230 | E | 12 | X | EA | LND | 1230 | URMA | 2011-05-10 | E-16-07-03 |  | 2011-12-10 |  | 2012-05-10 | 2011-07-11 |  |  |  |  |  |  |  |  |
| XE401230 |  | CA12 OthGrBasedEqpt - Install CableTrays | 30d | 2011-12-07 | 2012-01-17 | EE46123010 (other project), XE405102 SS+12d, XE401201 SS, XR401230 SS+25d |  |  | -3d | 0d |  | Cable trays/conduits [180 m]; Cable trays [540 h] | 21,600 |  | 540,00 | UDF_G3 |  | XE401230 | 540 | 0 |  | 934 | 12 | 200 | 200 | C | LND | X | E | XE40 | 1230 | E | 12 | X | EL | LND | 1230 | URMA | 2011-05-10 | E-15-01-09 |  | 2011-08-20 |  | 2011-12-20 | 2011-07-20 | m | 300 | 2011-06-29 | 2011-09-06 | x | to be checked |  |  |
| XE341230 |  | CA12 OthGrBasedEqpt - Install Local Operation Panels | 20d | 2012-01-18 | 2012-02-09 | XJ421230, EE46123010 (other project), XE401230, XR401230 SS+25d, P-21201A/B, P-21203 |  |  | 64d | 99.5d |  | Field Panels [2 pcs]; Field panels [40 h] | 1,600 |  | 40,00 |  |  | XE341230 | 40 | 0 |  | 934 | 12 | 200 | 200 | C | LND | X | E | XE34 | 1230 | E | 12 | X | EL | LND | 1230 | URMA | 2011-05-10 | E-16-07-03 |  | 2011-12-10 |  | 2012-05-10 | 2011-07-11 |  |  |  |  |  |  |  |  |
| XE801230 |  | CA12 OthGrBasedEqpt - Install Heat Tracing | 30d | 2012-03-05 | 2012-04-13 | XW501230 FF+20d, E3E1950 (other project), P3E19S (other project), XR401230, XR601230 FF+20d |  |  | 31d | 0d | TB26 - V - Construct-Winter partly * | Electrical Heat Tracing [700 m]; Electrical heat tracing [350 h] | 14,000 |  | 350,00 | UDF_G3 |  | XE801230 | 350 | 0 |  | 934 | 12 | 200 | 200 | C | LND | X | E | XE80 | 1230 | E | 12 | X | HT | LND | 1230 | URMA | 2011-06-20 | E-16-04-01 |  | 2012-03-20 |  | 2012-06-30 | 2011-09-15 |  |  |  |  |  |  | 005 |  |
| XE501230 |  | CA12 OthGrBasedEqpt - Cable Pulling Electric | 30d | 2012-06-09 | 2012-07-16 | XE500C01, P3E15AS (other project), P3E15CS (other project), P3E15BS (other project), XE401230, XE505102 SS+10d, EE561230 (other project), XE501201 SS, XE505401 SS+12d |  |  | -35.5d | 0d | TB26 - V - Construct-Winter partly * | Cable Pulling [2200 m]; Cable pulling [1100 h] | 44,000 |  | 1100,00 | UDF_G3 |  | XE501230 | 1100 | 0 |  | 934 | 12 | 200 | 200 | C | LND | X | E | XE50 | 1230 | E | 12 | X | EL | LND | 1230 | URMA | 2011-05-20 | E-16-01-01 |  | 2012-02-10 |  | 2012-07-01 | 2011-10-01 | m | 2300 | 2011-09-07 | 2011-11-22 |  |  |  |  |
| XE601230 |  | CA12 OthGrBasedEqpt - Cable Termination &Testing | 50d | 2012-06-09 | 2012-08-08 | XE501230 FF+20d, XE341230, P-21201A/B, P-21203 |  |  | -35.5d | 15d | TB26 - V - Construct-Winter partly * | Cable connecting [20 pcs]; Cable connecting [50 h] | 2,000 |  | 50,00 | UDF_G3 |  | XE601230 | 50 | 0 |  | 934 | 12 | 200 | 200 | C | LND | X | E | XE60 | 1230 | E | 12 | X | ET | LND | 1230 | URMA | 2011-04-20 | E-16-02-01 |  | 2011-11-30 |  | 2012-08-14 | 2011-12-10 |  |  |  |  |  |  |  |  |
|  | J | **Instrumentation** |  | 2011-12-01 | 2012-10-23 |  |  |  |  |  |  |  |  |  |  |  |  |  |  |  |  |  |  |  |  |  |  |  |  |  |  |  |  |  |  |  |  |  |  |  |  |  |  |  |  |  |  |  |  |  |  |  |  |
| XJ321230 |  | CA12 OthGrBasedEqpt - Install Junction Boxes | 10d | 2011-12-01 | 2011-12-12 | P3J06ES (other project) FS+14d, P-21201A/B FF+5d, P3J06FS (other project), XR401230 SS+20d, XN201201u, P-21203 FF+5d, EJ321230 (other project) |  |  | 2d | 5d |  | Junction Boxes/Cabinets/Panels [18 pcs]; Install Junction Boxes/ Cabinets/ Panels [450 h] | 18,000 |  | 450,00 |  |  | XJ321230 | 450 | 0 |  | 934 | 12 | 200 | 200 | C | LND | X | J | XJ32 | 1230 | J | 12 | X | IN | LND | 1230 | URMA | 2011-05-10 | E-17-04-03 |  | 2012-03-01 |  | 2012-08-15 | 2011-07-25 |  |  |  |  |  | to be installed later |  |  |
| XJ421230 |  | CA12 OthGrBasedEqpt - Install Secondary CableTrays | 30d | 2011-12-07 | 2012-01-17 | XJ321230 FF+20d, EJ46123010 (other project), XE401230 FF, XR401230 SS+25d, P-21201A/B, P-21203 |  |  | -3d | 0d |  | Secondary cable trays [180 m]; Install secondary cable trays [675 h] | 27,000 |  | 675,00 |  |  | XJ421230 | 675 | 0 |  | 934 | 12 | 200 | 200 | C | LND | X | J | XJ42 | 1230 | J | 12 | X | IN | LND | 1230 | URMA | 2011-05-10 | E-15-01-09 |  | 2011-08-20 |  | 2011-12-20 | 2011-07-20 | m | 330 | 2011-07-18 | 2011-09-24 | x | to be installed later |  |  |
| XJ441230 |  | CA12 OthGrBasedEqpt - Install Conduits to Instrm | 60d | 2012-01-18 | 2012-03-29 | XJ321230, P-21201A/B, P-21203, XR401230 SS+25d, XE401230, XJ421230 |  |  | -3d | 0d |  |  |  |  |  |  |  | XJ441230 | 0 | 0 |  | 934 | 12 | 200 | 200 | C | LND | X | J | XJ44 | 1230 | J | 12 | X | IN | LND | 1230 | URMA | 2011-05-10 | E-17-04-03 |  | 2012-03-01 |  | 2012-08-15 | 2011-07-25 |  |  |  |  |  | to be installed later |  |  |
| XJ301230 |  | CA12 OthGrBasedEqpt - Install Field Instruments | 60d | 2012-01-21 | 2012-04-02 | EJ361230 (other project), XR801230 FF, P3J04BS (other project), P3J04AS (other project), P3J05S (other project), XR401230 SS+25d, P-21201A/B, P-21203 |  |  | 14d | 0d |  | Field Instruments [90 pcs]; Install field instruments [495 h] | 19,800 |  | 495,00 | UDF_G3 |  | XJ301230 | 495 | 0 |  | 934 | 12 | 200 | 200 | C | LND | X | J | XJ30 | 1230 | J | 12 | X | IN | LND | 1230 | URMA | 2011-05-10 | E-17-04-03 |  | 2012-03-01 |  | 2012-08-15 | 2011-07-25 |  |  |  |  |  | to be checked |  |  |
| XJ541230 |  | CA12 OthGrBasedEqpt - Pulling Singlecore Cables | 40d | 2012-03-05 | 2012-04-25 | XJ421230, EJ801230 (other project), XJ441230 SS+10d, XE500C01, XJ301230 FF+20d |  |  | 39d | 42d | TB26 - V - Construct-Winter partly * | Singlecore cables [8800 m]; Pull singlecore cables [6600 h] | 264,000 |  | 6600,00 |  |  | XJ541230 | 6600 | 0 |  | 934 | 12 | 200 | 200 | C | LND | X | J | XJ54 | 1230 | J | 12 | X | IN | LND | 1230 | URMA | 2011-05-10 | E-17-04-03 |  | 2012-03-01 |  | 2012-08-15 | 2011-07-25 | m | 8473 | 2011-10-28 | 2011-12-14 |  |  |  |  |
| XJ701230 |  | CA12 OthGrBasedEqpt - Instrument Tubing | 40d | 2012-03-10 | 2012-04-25 | XJ301230 FF+20d, XR401230 |  |  | 14d | 17d |  |  |  |  |  |  |  | XJ701230 | 0 | 0 |  | 934 | 12 | 200 | 200 | C | LND | X | J | XJ70 | 1230 | J | 12 | X | IN | LND | 1230 | URMA | 2011-05-10 | E-17-04-03 |  | 2012-03-01 |  | 2012-08-15 | 2011-07-25 |  |  |  |  |  |  |  |  |
| XJ391230 |  | CA12 OthGrBasedEqpt - Install Earthing Field Eqp | 40d | 2012-03-30 | 2012-05-17 | XJ301230 FF+20d, XJ421230, XJ441230 |  |  | -3d | 0d |  |  |  |  |  | UDF_G3 |  | XJ391230 | 0 | 0 |  | 934 | 12 | 200 | 200 | C | LND | X | J | XJ39 | 1230 | J | 12 | X | IN | LND | 1230 | URMA | 2011-05-10 | E-17-04-03 |  | 2012-03-01 |  | 2012-08-15 | 2011-07-25 |  |  |  |  |  |  |  |  |
| XJ641230 |  | CA12 OthGrBasedEqpt - Termin Singlecore Cables | 40d | 2012-05-18 | 2012-07-04 | XJ301230, XJ541230 FF+15d, XJ391230, XJ321230, XJ701230 |  |  | -3d | 59.5d | TB26 - V - Construct-Winter partly * | Termination Field [705 mhr]; Termination field [705 h] | 70,500 |  | 705,00 |  |  | XJ641230 | 705 | 0 |  | 934 | 12 | 200 | 200 | C | LND | X | J | XJ64 | 1230 | J | 12 | X | IN | LND | 1230 | URMA | 2011-05-10 | E-17-04-03 |  | 2012-03-01 |  | 2012-08-15 | 2011-07-25 |  |  |  |  |  |  |  |  |
| XJ521230 |  | CA12 OthGrBasedEqpt - Pulling Multicore Cables | 40d | 2012-05-31 | 2012-07-18 | XJ525102 SS+10d, XJ321230 SS+20d, XE500C01, XE401230, XJ521201 SS, XJ525401 SS+12d |  |  | -7.5d | 0d | TB26 - V - Construct-Winter partly * | Multicore cables [4000 m]; Pull multicore cables [2000 h] | 80,000 |  | 2000,00 |  |  | XJ521230 | 2000 | 0 |  | 934 | 12 | 200 | 200 | C | LND | X | J | XJ52 | 1230 | J | 12 | X | IN | LND | 1230 | URMA | 2011-05-20 | E-17-01-01 |  | 2012-03-10 |  | 2012-06-16 | 2011-11-01 | m | 2900 | 2011-09-14 | 2011-10-29 |  | to be checked |  |  |
| XJ621230 |  | CA12 OthGrBasedEqpt - Termin Multicore Cables | 40d | 2012-06-13 | 2012-07-30 | XJ321230, XJ521230 FF+10d |  |  | -7.5d | 63d |  | Termination Field [705 mhr]; Termination field [705 h] | 70,500 |  | 705,00 |  |  | XJ621230 | 705 | 0 |  | 934 | 12 | 200 | 200 | C | LND | X | J | XJ62 | 1230 | J | 12 | X | IN | LND | 1230 | URMA | 2011-05-20 | E-17-01-01 |  | 2012-03-10 |  | 2012-06-16 | 2011-11-01 |  |  |  |  |  |  |  |  |
| XJ801230 |  | CA12 OthGrBasedEqpt - Inspections/ Mech. Acceptance/ Loop Checks | 50d | 2012-08-25 | 2012-10-23 | XE601230, X3J120, XJ641230 FF+10d, X030410030, XJ701230 SS, XJ391230 SS+10d, XJ621230 FF+10d |  |  | -50.5d | 32d |  | Loop Checks [350 pcs]; Loop checks [1750 h] | 70,000 |  | 1750,00 |  |  | XJ801230 | 1750 | 0 |  | 934 | 12 | 200 | 200 | C | LND | X | J | XJ80 | 1230 | J | 12 | X | LT | LND | 1230 | URMA | 2011-06-10 | E-17-02-01 |  | 2012-04-30 |  | 2012-08-18 | 2012-03-01 |  |  |  |  |  |  |  | 2012-08-18 |

| ID | WBS | Activity | Type | Duration | Start | Finish | Predecessors | Complete | Remaining | Total float | Free float | Constraint | Calendar | Resources | Cost | Actual cost | TB26 Ressource Budget | UDF_SELECT UPDATE PROGRESS | UDF_SAVE ACT ID | UDF_BUDGETED LABOR UNIT | UDF_ACTUAL LABOR UNIT | UDF_CHECK RESOURCE DATES | Department | Constr. Area | PMT-Area | PMT-Schedule Org | PMT-Phase | PMT-Respons. | WBS Phase | WBS Discipline | WBS Type of Work | WBS Objects | Russia WBS Discipline (Russia) | Russia Construction Area | Russia WBS Phase | IMS | UPT | Russia WBS Objects | Subcontractor | UDF_CONTRACT FINISH DATE | UDF_CONTRACT ITEM | Comments | UDF_Weight (ton) | WEIGHT | UDF_CONTRACT INDICATOR | UDF_LEVEL | UDF_PO No | UDF_TAG No | UDF_Object No | UDF_DELIVERY DATE PO | UDF_DELIVERY DATE DISPATCH PLANNED | UDF_DELIVERY DATE TO SITE PLANNED | UDF_DELIVERY DATE SITE NEED DATE | UDF_SHIPMENT No | UDF_PACKAGE | UDF_SUPPLIER | UDF_Vendor Representatives | Zeigen/n. Zeigen | Drawing Indicator | UDF_CONTRACT START DATE | Type of Work | 4 week lookahead | UDF_PLANNED START | UDF_PLANNED FINISH | UDF_CONTRACT FINISH DATE REV1 | UDF_CONTRACT START DATE REV1 | TB26 Semantics | TB26 Material Res Values | UDF_ELECTRICAL START | UDF_ELECTRICAL FINISH | UDF_CHECK BASELINE | UDF_COMMENTS_0827 |
| --- | --- | --- | --- | --- | --- | --- | --- | --- | --- | --- | --- | --- | --- | --- | --- | --- | --- | --- | --- | --- | --- | --- | --- | --- | --- | --- | --- | --- | --- | --- | --- | --- | --- | --- | --- | --- | --- | --- | --- | --- | --- | --- | --- | --- | --- | --- | --- | --- | --- | --- | --- | --- | --- | --- | --- | --- | --- | --- | --- | --- | --- | --- | --- | --- | --- | --- | --- | --- | --- | --- | --- | --- |
|  | W | **Painting** |  |  | 2011-07-30 | 2011-10-31 |  |  |  |  |  |  |  |  |  |  |  |  |  |  |  |  |  |  |  |  |  |  |  |  |  |  |  |  |  |  |  |  |  |  |  |  |  |  |  |  |  |  |  |  |  |  |  |  |  |  |  |  |  |  |  |  |  |  |  |  |  |  |  |  |  |  |
| XW501230 |  | CA12 OthGrBasedEqpt - Surf.Protection Piping |  | 80d | 2011-07-30 A | 2011-10-31 | XR201230 SS |  | 56d | 144d | 113d |  |  | Piping painting [473 sqm]; Piping painting [1183 h] | 734.65 |  | 1183,00 | 27.8. | XW501230 | 1183 | 0 | ok | 934 | 12 | 200 | 200 | C | LND | X | W | XW50 | 1230 | W | 12 | X | PA | LND | 1230 | VNZM |  |  |  |  |  |  |  |  |  |  |  |  |  |  |  |  |  |  |  |  |  |  |  |  |  |  |  |  |  |  |  |  |  |
|  | V | **Insulation** |  |  | 2012-04-03 | 2012-07-19 |  |  |  |  |  |  |  |  |  |  |  |  |  |  |  |  |  |  |  |  |  |  |  |  |  |  |  |  |  |  |  |  |  |  |  |  |  |  |  |  |  |  |  |  |  |  |  |  |  |  |  |  |  |  |  |  |  |  |  |  |  |  |  |  |  |  |
| XV301230 |  | CA12 OthGrBasedEqpt - Insulation Equipment |  | 90d | 2012-04-03 | 2012-07-19 | P-21203, P-21201A/B, XV300C00 SS, XE801230 SS+20d |  |  | 31d | 0d |  | TB26 - V - Construct-Winter partly * | Equipment insulation [200 sqm]; Equipment insulation [2500 h] | 523.27 |  | 2500,00 |  | XV301230 | 2500 | 0 |  | 934 | 12 | 200 | 200 | C | LND | X | V | XV30 | 1230 | V | 12 | X | INS | LND | 1230 | VNZM | 2012-03-30 | E-13-03 |  |  |  |  |  |  |  |  |  |  |  |  |  |  |  |  |  |  |  |  |  |  |  |  |  |  |  |  |  |  |  |
| XV501230 |  | CA12 OthGrBasedEqpt - Insulation Piping |  | 90d | 2012-04-03 | 2012-07-19 | XV301230 FF, XR601230 SS, XE801230 FF+20d |  |  | 31d | 113.5d |  | TB26 - V - Construct-Winter partly * | Piping insulation [450 sqm]; Piping insulation [3375 h] | 2,093.1 |  | 3375,00 |  | XV501230 | 3375 | 0 |  | 934 | 12 | 200 | 200 | C | LND | X | V | XV50 | 1230 | V | 12 | X | INS | LND | 1230 | VNZM | 2012-04-30 | E-13-01 |  |  |  |  |  |  |  |  |  |  |  |  |  |  |  |  |  |  |  |  |  |  |  |  |  |  |  |  |  |  |  |
|  | 31 | **CA12 - Reactor** |  |  |  |  |  |  |  |  |  |  |  |  |  |  |  |  |  |  |  |  |  |  |  |  |  |  |  |  |  |  |  |  |  |  |  |  |  |  |  |  |  |  |  |  |  |  |  |  |  |  |  |  |  |  |  |  |  |  |  |  |  |  |  |  |  |  |  |  |  |  |
|  | 32 | **CA12 - Recycle Gas Compressor** |  |  | 2010-09-27 | 2012-11-03 |  |  |  |  |  |  |  |  |  |  |  |  |  |  |  |  |  |  |  |  |  |  |  |  |  |  |  |  |  |  |  |  |  |  |  |  |  |  |  |  |  |  |  |  |  |  |  |  |  |  |  |  |  |  |  |  |  |  |  |  |  |  |  |  |  |  |
|  | C | **Civil Work** |  |  | 2010-09-27 | 2010-10-23 |  |  |  |  |  |  |  |  |  |  |  |  |  |  |  |  |  |  |  |  |  |  |  |  |  |  |  |  |  |  |  |  |  |  |  |  |  |  |  |  |  |  |  |  |  |  |  |  |  |  |  |  |  |  |  |  |  |  |  |  |  |  |  |  |  |  |
| XC201232 |  | CA12 R.G.Compressor SK1211 - Concrete Works Foundation |  | 24d | 2010-09-27 A | 2010-10-23 A | XC20120410 SS+20d, EC281232 (other project) FS+10d | 100% |  |  |  |  | TB26 - V - Construct-Winter partly * | Concrete works [150 cbm]; Concrete works [4500 h] | 1,385.79 |  | 4500,00 |  | XC201232 | 4500 | 4500 |  | 934 | 12 | 200 | 200 | C | MO03 | X | C | XC20 | 1232 | C | 12 | X | mis | LND | 1232 | MO11 |  |  |  |  |  |  |  |  |  |  |  |  |  |  |  |  |  |  |  |  |  |  |  |  |  |  |  |  |  |  |  |  |  |
|  | M | **Mechanical - Rotating Equipment** |  |  | 2011-08-02 | 2011-08-12 |  |  |  |  |  |  |  |  |  |  |  |  |  |  |  |  |  |  |  |  |  |  |  |  |  |  |  |  |  |  |  |  |  |  |  |  |  |  |  |  |  |  |  |  |  |  |  |  |  |  |  |  |  |  |  |  |  |  |  |  |  |  |  |  |  |  |
| K-21201A/B |  | RECYCLE GAS COMPRESSOR |  | 10d | 2011-08-02 A | 2011-08-12 A | XM101232 SS, XC201232, P3M02S1 (other project), R-21201, P3B150 (other project), XM101232 FF, XC201232 FF | 100% |  |  |  | start on or after 2011-08-02 |  | Rotating Equipment (w/ lube oil unit) [19.7 t]; Rotating equipment (w/ lube oil unit) [1638.35 h] | 78,800 |  | 1568,00 | 27.8. | K-21201A/B | 1638,35 | 0 |  |  | 12 |  |  |  |  | X | M |  | 1232 |  |  |  |  |  |  | VNZM |  |  | Heat Tracing Insulation ET60 | 17,124 | 8562 | UDF_G4 | concrete +0.00 | 2 DC 8490 | K-21201A/B | SK1232 | 2009-12-18 | 2010-11-30 | 2010-12-15 | 2010-11-20 | 1174-1176/1278 | M02 RECYCLE GAS COMPRESSOR (K-21-/22201A/B) | Sundstrand | 031 | EQ |  |  |  |  |  |  |  |  |  |  |  |  |  |  |
| XM101232 |  | CA12 R.G.Compressor - Install Rotating Eqpt | level of effort | 10d | 2011-08-02 A | 2011-08-12 A |  | 100% |  |  |  |  | TB26 - V - Construct-Winter partly * |  |  |  | 19 | 27.8. | XM101232 | 0 | 0 |  | 934 | 12 | 200 | 200 | C | LND | X | M | XM10 | 1232 | M | 12 | X | EQ | LND | 1232 | VNZM | 2011-05-10 | E-08-01-08 | E-08-01-08 |  |  |  |  |  |  |  |  |  |  |  |  |  | Sundstrand | 031 |  | UDF_G3 | 2011-03-10 | XBB |  |  |  |  |  |  |  |  |  |  |  |
|  | B | **Mechanical - Stationary Equipment** |  |  |  |  |  |  |  |  |  |  |  |  |  |  |  |  |  |  |  |  |  |  |  |  |  |  |  |  |  |  |  |  |  |  |  |  |  |  |  |  |  |  |  |  |  |  |  |  |  |  |  |  |  |  |  |  |  |  |  |  |  |  |  |  |  |  |  |  |  |  |
|  | R | **Piping** |  |  | 2011-07-30 | 2012-04-02 |  |  |  |  |  |  |  |  |  |  |  |  |  |  |  |  |  |  |  |  |  |  |  |  |  |  |  |  |  |  |  |  |  |  |  |  |  |  |  |  |  |  |  |  |  |  |  |  |  |  |  |  |  |  |  |  |  |  |  |  |  |  |  |  |  |  |
| XR201232 |  | CA12 R.G.Compressor SK1211 - Piping Prefabrication |  | 68d | 2011-07-30 A | 2011-10-17 | ER491232 (other project) SS+18d, P3R06S1 (other project), P3R06DS1 (other project), XR200C00 FS+25d, P3R06BS1 (other project) FS+10d |  | 44d | -30d | 440.5d |  |  | A/G piping prefabrication [980 Fpi]; A/G Piping (Prefab) [3675 h] | 3,569.8 |  | 3675,00 | 27.8. | XR201232 | 3675 | 0 | x | 934 | 12 | 200 | 200 | C | LND | X | R | XR20 | 1232 | R | 12 | X | PRP | LND | 1232 | VNZM |  |  |  |  |  | UDF_G4 |  |  |  |  |  |  |  |  |  |  |  |  |  |  |  |  | x |  |  |  |  |  |  |  |  |  |  |
| XR401232 |  | CA12 R.G.Compressor SK1211 - Piping Installation |  | 50d | 2011-10-13 | 2011-12-10 | XR201232 SS+2d, P3R03AS1 (other project) FF+20d, P3J04CS1 (other project), K-21201A/B FF+10d, P3J02DS (other project) FF+20d, P3J04IS (other project) FF+20d, P3R04S1 (other project) FF+20d, P3R07AS1 (other project), XR200C10, P3R09BS (other project) FF+10d, P3J02AS (other project) FF+20d, XN201201u FS+10d |  |  | -70d | 0d |  |  | A/G piping field installation [1200 Fpi]; Control & Shut-off valves [26 pcs]; Install Control & Shut-off Valves [136.5 h]; A/G Piping (Field) [7500 h] | 18,142.75 |  | 7636,50 |  | XR401232 | 7636,5 | 0 |  | 934 | 12 | 200 | 200 | C | LND | X | R | XR40 | 1232 | R | 12 | X | PI | LND | 1232 | VNZM |  | E-06-03-03 |  |  |  |  |  |  |  |  |  |  |  |  |  |  |  |  |  |  | 2011-01-10 |  |  | 2011-04-06 |  |  |  |  |  |  |  |  |  |
| XR801232 |  | CA12 R.G.Compressor SK1211 - Piping Reinstatement |  | 60d | 2012-01-21 | 2012-04-02 | IMS-C-000360 FF, XR601232 FF+10d |  |  | 14d | 0d |  |  |  |  |  | 131 |  | XR801232 | 0 | 0 |  | 934 | 12 | 200 | 200 | C | LND | X | R | XR80 | 1232 | R | 12 | X | PI | LND | 1232 | VNZM | 2011-10-30 | E-06-03-03 |  |  |  |  |  |  |  |  |  |  |  |  |  |  |  |  |  |  |  |  |  |  | 2012-01-30 |  |  |  |  |  |  |  |  |
| XR601232 |  | CA12 R.G.Compressor SK1211 - Piping Pressure Tests |  | 30d | 2012-02-14 | 2012-03-21 | X0300020, XR401232 FF+40d, XR605102 FF+20d |  |  | -109d | 0d |  |  |  |  |  | 263 |  | XR601232 | 0 | 0 |  | 934 | 12 | 200 | 200 | C | LND | X | R | XR60 | 1232 | R | 12 | X | HY | LND | 1232 | VNZM |  | E-06-03-03 |  |  |  |  |  |  |  |  |  |  |  |  |  |  |  |  |  |  |  |  |  |  |  |  |  |  |  |  |  |  |  |
|  | E | **Electrical** |  |  | 2010-09-30 | 2012-08-08 |  |  |  |  |  |  |  |  |  |  |  |  |  |  |  |  |  |  |  |  |  |  |  |  |  |  |  |  |  |  |  |  |  |  |  |  |  |  |  |  |  |  |  |  |  |  |  |  |  |  |  |  |  |  |  |  |  |  |  |  |  |  |  |  |  |  |
| XC911232 |  | CA12 R.G.Compressor - Install Earthing&LightnSys_CIVIL |  | 27d | 2010-09-30 A | 2010-10-30 A | EE901232 (other project), XC201232 FF+5d | 100% |  |  |  |  |  | Grounding & Lightning [50 pcs]; Grounding & Lightning [562.5 h] | 22,500 | 22,500 | 562,50 |  | XC911232 | 562,5 | 562,5 |  | 934 | 12 | 200 | 200 | C | LND | X | C | XE91 | 1232 | C | 12 | X | EA | LND | 1232 | MO11 |  |  |  |  |  |  |  |  |  |  |  |  |  |  |  |  |  |  |  |  |  |  |  |  |  |  |  |  |  |  |  |  |  |
| XE911242 |  | CA12 R.G.Compressor - Install Earthing&LightnSys_E/I |  | 5d | 2011-09-12 | 2011-09-16 | K-21201A/B FS+25d |  |  | 235d | 297.5d |  |  |  |  |  | 55 |  | XE911242 | 0 | 0 |  | 934 | 12 | 200 | 200 | C | LND | X | E | XE91 | 1232 | E | 12 | X | EA | LND | 1232 | URMA | 2011-12-10 | E-16-07-03 |  |  |  | UDF_G3 |  |  |  |  |  |  |  |  |  |  |  |  |  |  | 2011-05-10 |  |  |  |  | 2012-05-10 | 2011-07-11 |  |  |  |  |  |  |
| XE401232 |  | CA12 R.G.Compressor - Install Cable Trays |  | 30d | 2011-11-18 | 2011-12-22 | XE401201 SS+12d, XR401232 SS+30d, EE46123210 (other project), XN201201u |  |  | 43d | 0d | start on or after 2011-10-03 |  | Cable trays/conduits [180 m]; Cable trays [540 h] | 21,600 |  | 540,00 |  | XE401232 | 540 | 0 |  | 934 | 12 | 200 | 200 | C | LND | X | E | XE40 | 1232 | E | 12 | X | EL | LND | 1232 | URMA | 2011-08-20 | E-15-01-09 |  |  |  | UDF_G3 |  |  |  |  |  |  |  |  |  |  |  |  |  |  | 2011-05-10 |  |  |  |  | 2011-12-20 | 2011-07-20 | m | 300 | 2011-06-15 | 2011-08-23 | x |  |
| XE341232 |  | CA12 R.G.Compressor - Install Local Operation Panels |  | 10d | 2011-12-23 | 2012-01-10 | XE401232, XJ421232, EE46123210 (other project), XR401232 SS+25d, K-21201A/B |  |  | 90d | 155.5d |  |  | Field Panels [1 pcs]; Field panels [20 h] | 800 |  | 20,00 |  | XE341232 | 20 | 0 |  | 934 | 12 | 200 | 200 | C | LND | X | E | XE34 | 1232 | E | 12 | X | EL | LND | 1232 | URMA | 2011-12-10 | E-16-07-03 |  |  |  | UDF_G3 |  |  |  |  |  |  |  |  |  |  |  |  |  |  | 2011-05-10 |  |  |  |  | 2012-05-10 | 2011-07-11 |  |  |  |  |  |  |
| XE801232 |  | CA12 R.G.Compressor - Install Heat Tracing |  | 30d | 2012-03-03 | 2012-04-07 | XW501232 FF+20d, P3E19S (other project), E3E1950 (other project), K-21201A/B FS+10d, XR401232, XR601232 FF+15d |  |  | 32d | 0d |  |  | Electrical Heat Tracing [700 m]; Electrical heat tracing [350 h] | 14,000 |  | 350,00 | 27.8. | XE801232 | 350 | 0 |  | 934 | 12 | 200 | 200 | C | LND | X | E | XE80 | 1232 | E | 12 | X | HT | LND | 1232 | URMA | 2012-03-20 | E-16-04-01 |  |  |  | UDF_G3 |  |  |  |  |  |  |  |  |  |  |  | 005 |  |  | 2011-06-20 |  |  |  |  | 2012-06-30 | 2011-09-15 |  |  |  |  |  | to be installed later |
| XE501232 |  | CA12 R.G.Compressor - Cable Pulling Electric |  | 30d | 2012-06-09 | 2012-07-16 | EE561232 (other project), XE505102 SS+10d, XE500C01, XE401232, XE505401 SS+12d, XE501201 SS |  |  | -65.5d | 0d |  | TB26 - V - Construct-Winter partly * | Cable Pulling [2200 m]; Cable pulling [1100 h] | 44,000 |  | 1100,00 |  | XE501232 | 1100 | 0 |  | 934 | 12 | 200 | 200 | C | LND | X | E | XE50 | 1232 | E | 12 | X | EL | LND | 1232 | URMA | 2012-02-10 | E-16-01-01 |  |  |  | UDF_G3 |  |  |  |  |  |  |  |  |  |  |  |  |  |  | 2011-05-20 |  |  |  |  | 2012-07-01 | 2011-10-01 | m | 2300 | 2011-08-24 | 2011-11-01 |  |  |
| XE601232 |  | CA12 R.G.Compressor - Cable Termination &Testing |  | 50d | 2012-06-09 | 2012-08-08 | XE501232 FF+20d, XE341232 FF+20d, K-21201A/B |  |  | -65.5d | 15d |  | TB26 - V - Construct-Winter partly * | Cable connecting [20 pcs]; Cable connecting [50 h] | 2,000 |  | 50,00 |  | XE601232 | 50 | 0 |  | 934 | 12 | 200 | 200 | C | LND | X | E | XE60 | 1232 | E | 12 | X | ET | LND | 1232 | URMA | 2011-11-30 | E-16-02-01 |  |  |  | UDF_G3 |  |  |  |  |  |  |  |  |  |  |  |  |  |  | 2011-04-20 |  |  |  |  | 2012-08-14 | 2011-12-10 |  |  |  |  |  |  |

Notes:
- XW501230: P3 Activity Log Info: Clarification Surface Protection during Prefab
- XC201232: Scope: zweimal vorhanden
- K-21201A/B: Scope: K-21201A/B First Reactor Recycle Gas Compressors (17,124 / t) / K-21201A/B-P01 MAIN OIL PUMP (0,4 t) / K-21201A/B-V01 OIL RESERVOIR (0,4 / t) / K-22201A/B-P01 MAIN OIL PUMP (0,4 t) / K-22201A/B-V01 OIL RESERVOIR / (0,4)
- XE401232: Current Status: 20110727 (O.Siegel): die Cabel Trays / kцnnen erst installiert werden, wenn 1200 (Steel structure) fertiggestellt / wurde. Annahme heute, dass es zum 03.10.11 geschehen kann

| ID | WBS | Activity | Type | Duration | Start | Finish | Predecessors | Remaining | Total float | Free float | Constraint | Calendar | Resources | Cost | TB26 Ressource Budget | UDF_CONTRACT START DATE | UDF_CONTRACT FINISH DATE | UDF_CONTRACT ITEM | UDF_CONTRACT INDICATOR | UDF_CONTRACT FINISH DATE REV1 | UDF_CONTRACT START DATE REV1 | UDF_SAVE ACT ID | UDF_BUDGETED LABOR UNIT | UDF_ACTUAL LABOR UNIT | UDF_COMMENTS_0827 | Department | Constr. Area | PMT-Area | PMT-Schedule Org | PMT-Phase | PMT-Respons. | WBS Phase | WBS Discipline | WBS Type of Work | WBS Objects | Russia WBS Discipline (Russia) | Russia Construction Area | Russia WBS Phase | IMS | UPT | Russia WBS Objects | Subcontractor | TB26 Semantics | TB26 Material Res Values | UDF_ELECTRICAL START | UDF_ELECTRICAL FINISH | UDF_CHECK BASELINE | UDF_PENALIZED FINISH | UDF_SELECT UPDATE PROGRESS | UDF_CHECK RESOURCE DATES | 4 week lookahead | Comments | UDF_Text4 | UDF_Weight (ton) | WEIGHT | UDF_LEVEL | UDF_TAG No | UDF_Object No | UDF_PACKAGE | UDF_Vendor Representatives | Zeigen/n. Zeigen | Type of Work | UDF_CONSTRAINT COMMENT | UDF_PLANNED START | UDF_PLANNED FINISH |
| --- | --- | --- | --- | --- | --- | --- | --- | --- | --- | --- | --- | --- | --- | --- | --- | --- | --- | --- | --- | --- | --- | --- | --- | --- | --- | --- | --- | --- | --- | --- | --- | --- | --- | --- | --- | --- | --- | --- | --- | --- | --- | --- | --- | --- | --- | --- | --- | --- | --- | --- | --- | --- | --- | --- | --- | --- | --- | --- | --- | --- | --- | --- | --- | --- | --- |
|  | J | **Instrumentation** |  |  | 2011-11-12 | 2012-11-03 |  |  |  |  |  |  |  |  |  |  |  |  |  |  |  |  |  |  |  |  |  |  |  |  |  |  |  |  |  |  |  |  |  |  |  |  |  |  |  |  |  |  |  |  |  |  |  |  |  |  |  |  |  |  |  |  |  |  |  |
| XJ321232 |  | CA12 R.G.Compressor - Install Junction Boxes |  | 15d | 2011-11-12 | 2011-11-29 | EJ321232 (other project), P3J06FS (other project), K-21201A/B, P3J06ES (other project) FS+14d, XN201201u, XR401232 SS+25d |  | 56d | 13d |  |  | Junction Boxes/Cabinets/Panels [18 pcs]; Install Junction Boxes/ Cabinets/ Panels [450 h] | 18,000 | 450,00 | 2011-05-10 | 2012-03-01 | E-17-04-03 | UDF_G3 | 2012-08-15 | 2011-07-25 | XJ321232 | 450 | 0 | to be installed later | 934 | 12 | 200 | 200 | C | LND | X | J | XJ32 | 1232 | J | 12 | X | IN | LND | 1232 | URMA |  |  |  |  |  |  |  |  |  |  |  |  |  |  |  |  |  |  |  |  |  |  |  |
| XJ421232 |  | CA12 R.G.Compressor - Install Secondary Cable Trays |  | 20d | 2011-11-30 | 2011-12-22 | XJ321232 FF+7d, XE401232 FF, EJ46123210 (other project), XR401232 SS+25d, K-21201A/B |  | 43d | 0d |  |  | Secondary cable trays [120 m]; Install secondary cable trays [450 h] | 18,000 | 450,00 | 2011-05-10 | 2011-08-20 | E-15-01-09 |  | 2011-12-20 | 2011-07-20 | XJ421232 | 450 | 0 | to be installed later | 934 | 12 | 200 | 200 | C | LND | X | J | XJ42 | 1232 | J | 12 | X | IN | LND | 1232 | URMA | m | 220 | 2011-07-18 | 2011-09-24 | x |  |  |  |  |  |  |  |  |  |  |  |  |  |  |  |  |  |  |
| XJ441232 |  | CA12 R.G.Compressor - Install Conduits to Instrm |  | 40d | 2011-12-23 | 2012-02-14 | XJ321232, K-21201A/B, XR401232 SS+25d, XE401232, XJ421232 |  | 43d | 29d |  |  |  |  |  | 2011-05-10 | 2012-03-01 | E-17-04-03 |  | 2012-08-15 | 2011-07-25 | XJ441232 | 0 | 0 | to be installed later | 934 | 12 | 200 | 200 | C | LND | X | J | XJ44 | 1232 | J | 12 | X | IN | LND | 1232 | URMA |  |  |  |  |  |  |  |  |  |  |  |  |  |  |  |  |  |  |  |  |  |  |  |
| XJ301232 |  | CA12 R.G.Compressor - Install Field Instruments |  | 40d | 2012-02-14 | 2012-04-02 | P3J13CS (other project), P3J14AS (other project), P3J13BS (other project), P3J04AS (other project), P3J14S (other project), P3J12DS (other project), P3J04ES (other project), EJ361232 (other project), XR801232 FF, P3J12BS (other project), P3J14BS (other project), P3J04BS (other project), P3J13S (other project), P3J05S (other project), P3J13AS (other project), XR401232 SS+25d, K-21201A/B |  | 14d | 0d |  |  | Field Instruments [100 pcs]; Install field instruments [550 h] | 22,000 | 550,00 | 2011-05-10 | 2012-03-01 | E-17-04-03 | UDF_G3 | 2012-08-15 | 2011-07-25 | XJ301232 | 550 | 0 |  | 934 | 12 | 200 | 200 | C | LND | X | J | XJ30 | 1232 | J | 12 | X | IN | LND | 1232 | URMA |  |  |  |  |  |  |  |  |  |  |  |  |  |  |  |  |  |  |  |  |  |  |  |
| XJ391232 |  | CA12 R.G.Compressor - Install Earthing Field Eqp |  | 30d | 2012-03-22 | 2012-04-25 | XJ301232 FF+20d, XJ441232, XJ421232 |  | 14d | 39.5d |  |  |  |  |  | 2011-05-10 | 2012-03-01 | E-17-04-03 | UDF_G3 | 2012-08-15 | 2011-07-25 | XJ391232 | 0 | 0 |  | 934 | 12 | 200 | 200 | C | LND | X | J | XJ39 | 1232 | J | 12 | X | IN | LND | 1232 | URMA |  |  |  |  |  |  |  |  |  |  |  |  |  |  |  |  |  |  |  |  |  |  |  |
| XJ701232 |  | CA12 R.G.Compressor - Instrument Tubing |  | 30d | 2012-03-22 | 2012-04-25 | XJ301232 FF+20d, XR401232 |  | 14d | 39.5d |  |  |  |  |  | 2011-05-10 | 2012-03-01 | E-17-04-03 |  | 2012-08-15 | 2011-07-25 | XJ701232 | 0 | 0 |  | 934 | 12 | 200 | 200 | C | LND | X | J | XJ70 | 1232 | J | 12 | X | IN | LND | 1232 | URMA |  |  |  |  |  |  |  |  |  |  |  |  |  |  |  |  |  |  |  |  |  |  |  |
| XJ621232 |  | CA12 R.G.Compressor - Termin Multicore Cables |  | 40d | 2012-05-19 | 2012-07-06 | XJ521232 FF+10d, XJ321232 |  | -25.5d | 0d |  |  | Termination Field [705 mhr]; Termination field [705 h] | 70,500 | 705,00 | 2011-05-20 | 2012-03-10 | E-17-01-01 |  | 2012-06-16 | 2011-11-01 | XJ621232 | 705 | 0 | to be checked | 934 | 12 | 200 | 200 | C | LND | X | J | XJ62 | 1232 | J | 12 | X | IN | LND | 1232 | URMA |  |  |  |  |  |  |  |  |  |  |  |  |  |  |  |  |  |  |  |  |  |  |  |
| XJ541232 |  | CA12 R.G.Compressor - Pulling Singlecore Cables |  | 40d | 2012-05-26 | 2012-07-13 | XE500C01, XJ441232 SS+10d, XJ540C00 SS, EJ801232 (other project), XJ301232 FF+10d, XJ421232 |  | -25.5d | 0d | as late as possible | TB26 - V - Construct-Winter partly * | Singlecore cables [8800 m]; Pull singlecore cables [6600 h] | 264,000 | 6600,00 | 2011-05-10 | 2012-03-01 | E-17-04-03 |  | 2012-08-15 | 2011-07-25 | XJ541232 | 6600 | 0 |  | 934 | 12 | 200 | 200 | C | LND | X | J | XJ54 | 1232 | J | 12 | X | IN | LND | 1232 | URMA | m | 8425 | 2011-11-02 | 2011-12-19 |  |  |  |  |  |  |  |  |  |  |  |  |  |  |  |  |  |  |  |
| XJ521232 |  | CA12 R.G.Compressor - Pulling Multicore Cables |  | 20d | 2012-05-31 | 2012-06-25 | XJ525102 SS+10d, XJ321232 SS+20d, XE401232, XE500C01, XJ521201 SS, XJ525401 SS+12d |  | -25.5d | 0d |  | TB26 - V - Construct-Winter partly * | Multicore cables [3900 m]; Pull multicore cables [1950 h] | 78,000 | 1950,00 | 2011-05-20 | 2012-03-10 | E-17-01-01 |  | 2012-06-16 | 2011-11-01 | XJ521232 | 1950 | 0 | to be checked | 934 | 12 | 200 | 200 | C | LND | X | J | XJ52 | 1232 | J | 12 | X | IN | LND | 1232 | URMA | m | 2850 | 2011-09-14 | 2011-10-29 |  |  |  |  |  |  |  |  |  |  |  |  |  |  |  |  |  |  |  |
| XJ641232 |  | CA12 R.G.Compressor - Termin Singlecore Cables |  | 40d | 2012-06-14 | 2012-07-31 | XJ301232, XJ391232, XJ701232, XJ541232 FF+15d, XJ321232 |  | -25.5d | 37d |  | TB26 - V - Construct-Winter partly * | Termination Field [705 mhr]; Termination field [705 h] | 70,500 | 705,00 | 2011-05-10 | 2012-03-01 | E-17-04-03 |  | 2012-08-15 | 2011-07-25 | XJ641232 | 705 | 0 |  | 934 | 12 | 200 | 200 | C | LND | X | J | XJ64 | 1232 | J | 12 | X | IN | LND | 1232 | URMA |  |  |  |  |  |  |  |  |  |  |  |  |  |  |  |  |  |  |  |  |  |  |  |
| XJ801232 |  | CA12 R.G.Compressor - Inspections/ Mech. Acceptance/ Loop Checks |  | 60d | 2012-08-25 | 2012-11-03 | XE601232, X3J120, XJ641232 FF+15d, XJ701232 SS, X030410030, XJ800C00 SS, XJ391232 SS+10d, X0300015, EJ801232 (other project), XJ621232 FF+15d |  | -80.5d | 2d |  | TB26 - V - Construct-Winter partly * | Loop Checks [260 pcs]; Loop checks [1300 h] | 52,000 | 1300,00 | 2011-06-10 | 2012-04-30 | E-17-02-01 |  | 2012-08-18 | 2012-03-01 | XJ801232 | 1300 | 0 |  | 934 | 12 | 200 | 200 | C | LND | X | J | XJ80 | 1232 | J | 12 | X | LT | LND | 1232 | URMA |  |  |  |  |  | 2012-08-18 |  |  |  |  |  |  |  |  |  |  |  |  |  |  |  |  |  |
|  | W | **Painting** |  |  | 2011-08-23 | 2011-09-20 |  |  |  |  |  |  |  |  |  |  |  |  |  |  |  |  |  |  |  |  |  |  |  |  |  |  |  |  |  |  |  |  |  |  |  |  |  |  |  |  |  |  |  |  |  |  |  |  |  |  |  |  |  |  |  |  |  |  |  |
| XW501232 |  | CA12 R.G.Compressor - Surf.Protection Piping |  | 25d | 2011-08-23 A | 2011-09-20 | XR201232 SS+20d | 21d | 175d | 143d |  |  | Piping painting [331 sqm]; Piping painting [828 h] | 514.41 | 828,00 |  |  |  |  |  |  | XW501232 | 828 | 0 |  | 934 | 12 | 200 | 200 | C | LND | X | W | XW50 | 1232 | W | 12 | X | PA | LND | 1232 | VNZM |  |  |  |  |  |  | 27.8. | x |  |  |  |  |  |  |  |  |  |  |  |  |  |  |  |
|  | V | **Insulation** |  |  | 2012-02-25 | 2012-07-18 |  |  |  |  |  |  |  |  |  |  |  |  |  |  |  |  |  |  |  |  |  |  |  |  |  |  |  |  |  |  |  |  |  |  |  |  |  |  |  |  |  |  |  |  |  |  |  |  |  |  |  |  |  |  |  |  |  |  |  |
| XV501232 |  | CA12 R.G.Compressor - Insulation Piping |  | 120d | 2012-02-25 | 2012-07-18 | XV301232 FF+24d, XE801232 FF+20d, XR601232 SS |  | 32d | 114.5d |  |  | Piping insulation [300 sqm]; Piping insulation [2250 h] | 1,466.35 | 2250,00 |  | 2012-04-30 | E-13-01 |  |  |  | XV501232 | 2250 | 0 |  | 934 | 12 | 200 | 200 | C | LND | X | V | XV50 | 1232 | V | 12 | X | INS | LND | 1232 | VNZM |  |  |  |  |  |  |  |  |  |  |  |  |  |  |  |  |  |  |  |  |  |  |  |
| XV301232 |  | CA12 R.G.Compressor - Insulation Equipment |  | 70d | 2012-03-28 | 2012-06-20 | XE801232 SS+20d, XV300C00 SS, K-21201A/B |  | 32d | 0d |  |  | Equipment insulation [100 sqm]; Equipment insulation [1250 h] | 368.07 | 1250,00 |  | 2012-03-30 | E-13-03 |  |  |  | XV301232 | 1250 | 0 |  | 934 | 12 |  |  |  | LND | X | V | XV30 | 1232 | V | 12 | X | INS | LND | 1232 | VNZM |  |  |  |  |  |  |  |  |  |  |  |  |  |  |  |  |  |  |  |  |  |  |  |
|  | 33 | **CA12 - Bleed Booster Compressor** |  |  | 2011-07-30 | 2012-10-23 |  |  |  |  |  |  |  |  |  |  |  |  |  |  |  |  |  |  |  |  |  |  |  |  |  |  |  |  |  |  |  |  |  |  |  |  |  |  |  |  |  |  |  |  |  |  |  |  |  |  |  |  |  |  |  |  |  |  |  |
|  | C | **Civil Work** |  |  | 2011-11-08 | 2011-11-17 |  |  |  |  |  |  |  |  |  |  |  |  |  |  |  |  |  |  |  |  |  |  |  |  |  |  |  |  |  |  |  |  |  |  |  |  |  |  |  |  |  |  |  |  |  |  |  |  |  |  |  |  |  |  |  |  |  |  |  |
| XC201233 |  | CA12 B.B.Compressor(K21801) - Concrete Works Foundation |  | 7d | 2011-11-08 | 2011-11-17 | EC281233 (other project) FS+10d, XC201232 SS+15d, XN201204, XC201230 |  | 5d | 0d |  | TB26 - V - Construct-Winter partly * | Concrete works [60 cbm]; Concrete works [1800 h] | 461.93 | 1800,00 |  |  |  |  |  |  | XC201233 | 1800 | 0 |  | 934 | 12 | 200 | 200 | C | MO03 | X | C | XC20 | 1233 | C | 12 | X | mis | LND | 1233 | MO11 |  |  |  |  |  |  |  |  | x |  |  |  |  |  |  |  |  |  |  |  |  |  |  |
|  | M | **Mechanical - Rotating Equipment** |  |  | 2011-11-23 | 2011-12-03 |  |  |  |  |  |  |  |  |  |  |  |  |  |  |  |  |  |  |  |  |  |  |  |  |  |  |  |  |  |  |  |  |  |  |  |  |  |  |  |  |  |  |  |  |  |  |  |  |  |  |  |  |  |  |  |  |  |  |  |
| K-21801 |  | GAS BLEED BOOSTER COMPRESSOR |  | 10d | 2011-11-23 | 2011-12-03 | XM101233 FF, XM101233 SS, P3M04S (other project), XC911233, XC201233 |  | 7d | 0d |  |  | Rotating Equipment (w/ lube oil unit) [19.9 t]; Rotating equipment (w/ lube oil unit) [1566.25 h] | 79,600 | 1566,25 |  |  |  |  |  |  | K-21801 | 1566,25 | 0 |  |  | 12 |  |  |  |  | X | M |  | 1233 |  |  |  |  |  |  | VNZM |  |  |  |  |  |  |  |  |  | Install Heat Tracing ET | TEAL Neutralization | 16 | 16000 | concrete +0.00 | K-21801 | SK1233 | M04 GAS BLEED COMPRESSOR (K-21801) | 032 | EQ |  |  |  |  |
| XM101233 |  | CA12 B.B.Compressor - Install Rotating Eqpt | level of effort | 5d | 2011-11-23 | 2011-11-30 |  |  | 4d | 0d |  | TB26 - V - Construct-Winter partly * |  |  | 18 | 2011-03-10 | 2011-05-10 | E-08-01-08 |  |  |  | XM101233 | 0 | 0 |  | 934 | 12 | 200 | 200 | C | LND | X | M | XM10 | 1233 | M | 12 | X | EQ | LND | 1233 | VNZM |  |  |  |  |  |  |  |  |  |  |  |  |  |  |  |  |  | 032 |  | XBB |  |  |  |
|  | B | **Mechanical - Stationary Equipment** |  |  |  |  |  |  |  |  |  |  |  |  |  |  |  |  |  |  |  |  |  |  |  |  |  |  |  |  |  |  |  |  |  |  |  |  |  |  |  |  |  |  |  |  |  |  |  |  |  |  |  |  |  |  |  |  |  |  |  |  |  |  |  |
|  | R | **Piping** |  |  | 2011-07-30 | 2012-04-03 |  |  |  |  |  |  |  |  |  |  |  |  |  |  |  |  |  |  |  |  |  |  |  |  |  |  |  |  |  |  |  |  |  |  |  |  |  |  |  |  |  |  |  |  |  |  |  |  |  |  |  |  |  |  |  |  |  |  |  |
| XR201233 |  | CA12 B.B.Compressor - Piping Prefabrication |  | 62d | 2011-07-30 A | 2011-10-10 | ER491233 (other project) FS+20d | 38d | 65d | 446.5d |  |  | A/G piping prefabrication [560 Fpi]; A/G Piping (Prefab) [2100 h] | 2,039.88 | 2100,00 |  |  |  | UDF_G4 |  |  | XR201233 | 2100 | 0 |  | 934 | 12 | 200 | 200 | C | LND | X | R | XR20 | 1233 | R | 12 | X | PRP | LND | 1233 | VNZM |  |  |  |  |  |  | 27.8. | actual finish | x |  |  |  |  |  |  |  |  |  |  |  | as per 30.4.12 schedule |  |  |
| XR401233 |  | CA12 B.B.Compressor - Piping Installation |  | 50d | 2011-11-11 | 2012-01-14 | K-21801 FF+30d, P3J02S (other project) FF+20d, P3J02DS (other project) FF+20d, XR201233 SS+30d, P3J04CS1 (other project), P3J01AS (other project) FF+20d, P3J02AS (other project) FF+20d, P3J04IS (other project) FF+20d |  | 7d | 0d |  |  | A/G piping field installation [680 Fpi]; Control & Shut-off valves [26 pcs]; Install Control & Shut-off Valves [136.5 h]; A/G Piping (Field) [4250 h] | 12,703.06 | 4386,50 | 2011-01-10 |  | E-06-03-03 |  |  |  | XR401233 | 4386,5 | 0 |  | 934 | 12 | 200 | 200 | C | LND | X | R | XR40 | 1233 | R | 12 | X | PI | LND | 1233 | VNZM |  |  |  |  |  |  |  |  |  |  |  |  |  |  |  |  |  |  |  |  |  | 2011-04-06 |  |
| XR601233 |  | CA12 B.B.Compressor - Piping Pressure Tests |  | 30d | 2012-02-15 | 2012-03-22 | XR605102 FF+21d, XR401233 FF+25d, X0300020 |  | 13d | 0d |  |  |  |  | 150 |  |  | E-06-03-03 |  |  |  | XR601233 | 0 | 0 |  | 934 | 12 | 200 | 200 | C | LND | X | R | XR60 | 1233 | R | 12 | X | HY | LND | 1233 | VNZM |  |  |  |  |  |  |  |  |  |  |  |  |  |  |  |  |  |  |  |  |  |  |  |
| XR801233 |  | CA12 B.B.Compressor - Piping Reinstatement |  | 30d | 2012-02-28 | 2012-04-03 | XR601233 FF+10d, IMS-C-000360 FF |  | 13d | 0d |  |  |  |  | 75 |  | 2011-10-30 | E-06-03-03 |  |  |  | XR801233 | 0 | 0 |  | 934 | 12 | 200 | 200 | C | LND | X | R | XR80 | 1233 | R | 12 | X | PI | LND | 1233 | VNZM |  |  |  |  |  |  |  |  |  |  |  |  |  |  |  |  |  |  |  |  |  |  | 2012-01-30 |

Notes:
- XW501232: P3 Activity Log Info: Clarification Surface Protection during Prefab
- XC201233: Current Status: 18.02.2011 (O. Siegel): die Zeichnungens ind vorhanden. / Die Civil-Arbeiten kцnnen erst durchgefьhrt werden, wenn HGT-Schicht gelegt / werden kann, d.h. erst wenn der Grund frostfrei ist. dieser muss sich setzten, / damit das Backfilling durchgefьhrt werden kann um dann darauf die Fundamente zu / bauen. AnschlieЯend Montage des Equipments. / Scope: einmal vorhanden
- K-21801: Scope: K-21801 Gas Bleed Booster Compressor / K-21801-V01 Booster Compressor Suction KO Drum (0,95 t) / K-21801-V02 Booster Compressor Discharge Drum (0,95 t)

| ID | WBS | Activity | Duration | Start | Finish | Predecessors | Remaining | Total float | Free float | Calendar | Resources | Cost | TB26 Ressource Budget | UDF_SAVE ACT ID | UDF_BUDGETED LABOR UNIT | UDF_ACTUAL LABOR UNIT | Department | Constr. Area | PMT-Area | PMT-Schedule Org | PMT-Phase | PMT-Respons. | WBS Phase | WBS Discipline | WBS Type of Work | WBS Objects | Russia WBS Discipline (Russia) | Russia Construction Area | Russia WBS Phase | IMS | UPT | Russia WBS Objects | Subcontractor | UDF_CONTRACT START DATE | UDF_CONTRACT FINISH DATE | UDF_CONTRACT ITEM | UDF_CONTRACT INDICATOR | TB26 Semantics | TB26 Material Res Values | UDF_ELECTRICAL START | UDF_ELECTRICAL FINISH | UDF_CONTRACT FINISH DATE REV1 | UDF_CONTRACT START DATE REV1 | UDF_CHECK BASELINE | UDF_COMMENTS_0827 | UDF_Vendor Representatives | UDF_PENALIZED FINISH | UDF_SELECT UPDATE PROGRESS | UDF_CHECK RESOURCE DATES |
| --- | --- | --- | --- | --- | --- | --- | --- | --- | --- | --- | --- | --- | --- | --- | --- | --- | --- | --- | --- | --- | --- | --- | --- | --- | --- | --- | --- | --- | --- | --- | --- | --- | --- | --- | --- | --- | --- | --- | --- | --- | --- | --- | --- | --- | --- | --- | --- | --- | --- |
|  | E | **Electrical** |  | 2011-11-15 | 2012-08-08 |  |  |  |  |  |  |  |  |  |  |  |  |  |  |  |  |  |  |  |  |  |  |  |  |  |  |  |  |  |  |  |  |  |  |  |  |  |  |  |  |  |  |  |  |
| XC911233 |  | CA12 B.B.Compressor - Install Earthing&LightnSys_CIVIL | 5d | 2011-11-15 | 2011-11-22 | XC201233 FF+2d, EE901233 (other project) |  | 5d | 0d | TB26 - V - Construct-Winter partly * | Grounding & Lightning [50 pcs]; Grounding & Lightning [562.5 h] | 22,500 | 562,50 | XC911233 | 562,5 | 0 | 934 | 12 | 200 | 200 | C | LND | X | C | XE91 | 1233 | C | 12 | X | EA | LND | 1233 | MO11 |  |  |  |  |  |  |  |  |  |  |  |  |  |  |  |  |
| XE401233 |  | CA12 B.B.Compressor - Install Cable Trays | 30d | 2011-12-05 | 2012-01-14 | EE46123310 (other project), XR401233 SS+20d |  | 19d | 12d |  | Cable trays/conduits [180 m]; Cable trays [540 h] | 21,600 | 540,00 | XE401233 | 540 | 0 | 934 | 12 | 200 | 200 | C | LND | X | E | XE40 | 1233 | E | 12 | X | EL | LND | 1233 | URMA | 2011-05-10 | 2011-08-20 | E-15-01-09 | UDF_G3 | m | 300 | 2011-07-18 | 2011-09-13 | 2011-12-20 | 2011-07-20 | x | to be checked |  |  |  |  |
| XE911234 |  | CA12 B.B.Compressor - Install Earthing&LightnSys_E/I | 10d | 2011-12-05 | 2011-12-26 | XC201233, K-21801 |  | 122d | 184.5d | TB26 - V - Construct-Winter partly * |  |  | 55 | XE911234 | 0 | 0 | 934 | 12 | 200 | 200 | C | LND | X | E | XE91 | 1233 | E | 12 | X | EA | LND | 1233 | URMA | 2011-05-10 | 2011-12-10 | E-16-07-03 | UDF_G3 |  |  |  |  | 2012-05-10 | 2011-07-11 |  |  |  |  |  |  |
| XE341233 |  | CA12 B.B.Compressor - Install Local Operation Panels | 10d | 2012-01-30 | 2012-02-09 | XE401233, XJ421233, EE46123310 (other project), XR401233 SS+40d, K-21801 |  | 64d | 99.5d |  | Field Panels [1 pcs]; Field panels [20 h] | 800 | 20,00 | XE341233 | 20 | 0 | 934 | 12 | 200 | 200 | C | LND | X | E | XE34 | 1233 | E | 12 | X | EL | LND | 1233 | URMA | 2011-05-10 | 2011-12-10 | E-16-07-03 |  |  |  |  |  | 2012-05-10 | 2011-07-11 |  |  |  |  |  |  |
| XE801233 |  | CA12 B.B.Compressor - Install Heat Tracing | 30d | 2012-03-05 | 2012-04-09 | K-21801, XW501233 FF+20d, P3E19S (other project), E3E1950 (other project), XR401233, XR601233 FF+15d |  | 47d | 0d |  | Electrical Heat Tracing [700 m]; Electrical heat tracing [350 h] | 14,000 | 350,00 | XE801233 | 350 | 0 | 934 | 12 | 200 | 200 | C | LND | X | E | XE80 | 1233 | E | 12 | X | HT | LND | 1233 | URMA | 2011-06-20 | 2012-03-20 | E-16-04-01 | UDF_G3 |  |  |  |  | 2012-06-30 | 2011-09-15 |  | to be checked | 005 |  |  |  |
| XE501233 |  | CA12 B.B.Compressor - Cable Pulling Electric | 30d | 2012-06-09 | 2012-07-16 | XE500C01, XE505102 SS+10d, XE401233, EE561233 (other project), XE501201 SS, XE505401 SS+12d |  | -35.5d | 0d | TB26 - V - Construct-Winter partly * | Cable Pulling [2200 m]; Cable pulling [1100 h] | 44,000 | 1100,00 | XE501233 | 1100 | 0 | 934 | 12 | 200 | 200 | C | LND | X | E | XE50 | 1233 | E | 12 | X | EL | LND | 1233 | URMA | 2011-05-20 | 2012-02-10 | E-16-01-01 | UDF_G3 | m | 2300 | 2011-09-14 | 2012-03-01 | 2012-07-01 | 2011-10-01 |  |  |  |  |  |  |
| XE601233 |  | CA12 B.B.Compressor - Cable Termination &Testing | 50d | 2012-06-09 | 2012-08-08 | XE501233 FF+20d, XE341233, K-21801 |  | -35.5d | 30d | TB26 - V - Construct-Winter partly * | Cable connecting [20 pcs]; Cable connecting [50 h] | 2,000 | 50,00 | XE601233 | 50 | 0 | 934 | 12 | 200 | 200 | C | LND | X | E | XE60 | 1233 | E | 12 | X | ET | LND | 1233 | URMA | 2011-04-20 | 2011-11-30 | E-16-02-01 | UDF_G3 |  |  |  |  | 2012-08-14 | 2011-12-10 |  |  |  |  |  |  |
|  | J | **Instrumentation** |  | 2011-12-28 | 2012-10-23 |  |  |  |  |  |  |  |  |  |  |  |  |  |  |  |  |  |  |  |  |  |  |  |  |  |  |  |  |  |  |  |  |  |  |  |  |  |  |  |  |  |  |  |  |
| XJ321233 |  | CA12 B.B.Compressor - Install Junction Boxes | 15d | 2011-12-28 | 2012-01-20 | XC201233, P3J06ES (other project) FS+14d, EJ321233 (other project), XN201201u, P3J06FS (other project), K-21801, XR401233 SS+40d |  | 7d | 0d |  | Junction Boxes/Cabinets/Panels [18 pcs]; Install Junction Boxes/ Cabinets/ Panels [450 h] | 18,000 | 450,00 | XJ321233 | 450 | 0 | 934 | 12 | 200 | 200 | C | LND | X | J | XJ32 | 1233 | J | 12 | X | IN | LND | 1233 | URMA | 2011-05-10 | 2012-03-01 | E-17-04-03 | UDF_G3 |  |  |  |  | 2012-08-15 | 2011-07-25 |  | to be installed later |  |  |  |  |
| XJ421233 |  | CA12 B.B.Compressor - Install Secondary Cable Trays | 20d | 2011-12-30 | 2012-01-28 | EJ46123310 (other project), XE401233 FF, XJ321233 FF+7d, XR401233 SS+25d, K-21801 |  | 7d | 0d |  | Secondary cable trays [120 m]; Install secondary cable trays [450 h] | 18,000 | 450,00 | XJ421233 | 450 | 0 | 934 | 12 | 200 | 200 | C | LND | X | J | XJ42 | 1233 | J | 12 | X | IN | LND | 1233 | URMA | 2011-05-10 | 2011-08-20 | E-15-01-09 |  | m | 220 | 2011-07-18 | 2011-09-13 | 2011-12-20 | 2011-07-20 | x | to be installed later |  |  |  |  |
| XJ441233 |  | CA12 B.B.Compressor - Install Conduits to Instrm | 50d | 2012-01-30 | 2012-03-29 | XJ321233, XR401233 SS+25d, K-21801, XE401233, XJ421233 |  | 7d | 0d |  |  |  |  | XJ441233 | 0 | 0 | 934 | 12 | 200 | 200 | C | LND | X | J | XJ44 | 1233 | J | 12 | X | IN | LND | 1233 | URMA | 2011-05-10 | 2012-03-01 | E-17-04-03 |  |  |  |  |  | 2012-08-15 | 2011-07-25 |  | to be installed later |  |  |  |  |
| XJ301233 |  | CA12 B.B.Compressor - Install Field Instruments | 40d | 2012-02-15 | 2012-04-03 | P3J04AS (other project), EJ361233 (other project), XR801233 FF, P3J05S (other project), P3J04BS (other project), XR401233 SS+20d, K-21801 |  | 13d | 0d |  | Field Instruments [100 pcs]; Install field instruments [550 h] | 22,000 | 550,00 | XJ301233 | 550 | 0 | 934 | 12 | 200 | 200 | C | LND | X | J | XJ30 | 1233 | J | 12 | X | IN | LND | 1233 | URMA | 2011-05-10 | 2012-03-01 | E-17-04-03 | UDF_G3 |  |  |  |  | 2012-08-15 | 2011-07-25 |  |  |  |  |  |  |
| XJ541233 |  | CA12 B.B.Compressor - Pulling Singlecore Cables | 40d | 2012-03-12 | 2012-04-30 | XJ421233, XJ301233 SS+20d, XJ441233 SS+10d, XE500C01, XE401233, EJ801233 (other project) |  | 35d | 28d | TB26 - V - Construct-Winter partly * | Singlecore cables [8800 m]; Pull singlecore cables [6600 h] | 264,000 | 6600,00 | XJ541233 | 6600 | 0 | 934 | 12 | 200 | 200 | C | LND | X | J | XJ54 | 1233 | J | 12 | X | IN | LND | 1233 | URMA | 2011-05-10 | 2012-03-01 | E-17-04-03 |  | m | 8473 | 2011-10-19 | 2011-12-05 | 2012-08-15 | 2011-07-25 |  |  |  |  |  |  |
| XJ701233 |  | CA12 B.B.Compressor - Instrument Tubing | 30d | 2012-03-23 | 2012-04-26 | XJ301233 FF+20d, XR401233 |  | 13d | 6d |  |  |  |  | XJ701233 | 0 | 0 | 934 | 12 | 200 | 200 | C | LND | X | J | XJ70 | 1233 | J | 12 | X | IN | LND | 1233 | URMA | 2011-05-10 | 2012-03-01 | E-17-04-03 |  |  |  |  |  | 2012-08-15 | 2011-07-25 |  |  |  |  |  |  |
| XJ391233 |  | CA12 B.B.Compressor - Install Earthing Field Eqp | 30d | 2012-03-30 | 2012-05-04 | XJ301233 FF+20d, XJ421233, XJ441233 |  | 7d | 0d |  |  |  |  | XJ391233 | 0 | 0 | 934 | 12 | 200 | 200 | C | LND | X | J | XJ39 | 1233 | J | 12 | X | IN | LND | 1233 | URMA | 2011-05-10 | 2012-03-01 | E-17-04-03 | UDF_G3 |  |  |  |  | 2012-08-15 | 2011-07-25 |  |  |  |  |  |  |
| XJ641233 |  | CA12 B.B.Compressor - Termin Singlecore Cables | 40d | 2012-05-05 | 2012-06-22 | XJ701233, XJ391233, XJ301233, XJ541233 FF+15d |  | 7d | 69.5d |  | Termination Field [705 mhr]; Termination field [705 h] | 70,500 | 705,00 | XJ641233 | 705 | 0 | 934 | 12 | 200 | 200 | C | LND | X | J | XJ64 | 1233 | J | 12 | X | IN | LND | 1233 | URMA | 2011-05-10 | 2012-03-01 | E-17-04-03 |  |  |  |  |  | 2012-08-15 | 2011-07-25 |  |  |  |  |  |  |
| XJ621233 |  | CA12 B.B.Compressor - Termin Multicore Cables | 40d | 2012-05-25 | 2012-07-12 | XJ321233, XJ521233 FF+10d |  | 222d |  |  | Termination Field [705 mhr]; Termination field [705 h] | 70,500 | 705,00 | XJ621233 | 705 | 0 | 934 | 12 | 200 | 200 | C | LND | X | J | XJ62 | 1233 | J | 12 | X | IN | LND | 1233 | URMA | 2011-05-20 | 2012-03-10 | E-17-01-01 |  |  |  |  |  | 2012-06-16 | 2011-11-01 |  | to be checked |  |  |  |  |
| XJ521233 |  | CA12 B.B.Compressor - Pulling Multicore Cables | 20d | 2012-06-06 | 2012-06-30 | XJ321233 SS+10d, XE401233, XJ521232 SS+5d, XE500C01, XJ521201 SS, XJ525401 SS+12d, XJ525102 SS+10d |  | 223d | 0d | TB26 - V - Construct-Winter partly * | Multicore cables [3900 m]; Pull multicore cables [1950 h] | 78,000 | 1950,00 | XJ521233 | 1950 | 0 | 934 | 12 | 200 | 200 | C | LND | X | J | XJ52 | 1233 | J | 12 | X | IN | LND | 1233 | URMA | 2011-05-20 | 2012-03-10 | E-17-01-01 |  | m | 2850 | 2011-09-14 | 2011-10-29 | 2012-06-16 | 2011-11-01 |  | to be checked |  |  |  |  |
| XJ801233 |  | CA12 B.B.Compressor - Inspections/ Mech. Acceptance/ Loop Checks | 50d | 2012-08-25 | 2012-10-23 | X030410030, XJ701233, XJ641233 FF+20d, XJ391233 FS+10d, X3J120, EJ801233 (other project), X0300015, XE601233 FS-20d, XJ800C00 SS |  | -70.5d | 12d | TB26 - V - Construct-Winter partly * | Loop Checks [260 pcs]; Loop checks [1300 h] | 52,000 | 1300,00 | XJ801233 | 1300 | 0 | 934 | 12 | 200 | 200 | C | LND | X | J | XJ80 | 1233 | J | 12 | X | LT | LND | 1233 | URMA | 2011-06-10 | 2012-04-30 | E-17-02-01 |  |  |  |  |  | 2012-08-18 | 2012-03-01 |  |  |  | 2012-08-18 |  |  |
|  | W | **Painting** |  | 2011-07-30 | 2011-10-01 |  |  |  |  |  |  |  |  |  |  |  |  |  |  |  |  |  |  |  |  |  |  |  |  |  |  |  |  |  |  |  |  |  |  |  |  |  |  |  |  |  |  |  |  |
| XW501233 |  | CA12 B.B.Compressor - Surf.Protection Piping | 55d | 2011-07-30 A | 2011-10-01 | XR201233 SS | 31d | 181d | 134d |  | Piping painting [189 sqm]; Piping painting [473 h] | 294.16 | 473,00 | XW501233 | 473 | 0 | 934 | 12 | 200 | 200 | C | LND | X | W | XW50 | 1233 | W | 12 | X | PA | LND | 1233 | VNZM |  |  |  |  |  |  |  |  |  |  |  |  |  |  | 27.8. | ok |
|  | V | **Insulation** |  | 2012-03-02 | 2012-06-30 |  |  |  |  |  |  |  |  |  |  |  |  |  |  |  |  |  |  |  |  |  |  |  |  |  |  |  |  |  |  |  |  |  |  |  |  |  |  |  |  |  |  |  |  |
| XV501233 |  | CA12 B.B.Compressor - Insulation Piping | 100d | 2012-03-02 | 2012-06-30 | XR601233 SS, XV301233 FF+18d, XE801233 FF+20d |  | 47d | 129.5d |  | Piping insulation [160 sqm]; Piping insulation [1200 h] | 839.6 | 1200,00 | XV501233 | 1200 | 0 | 934 | 12 | 200 | 200 | C | LND | X | V | XV50 | 1233 | V | 12 | X | INS | LND | 1233 | VNZM |  | 2012-04-30 | E-13-01 |  |  |  |  |  |  |  |  |  |  |  |  |  |
| XV301233 |  | CA12 B.B.Compressor - Insulation Equipment | 60d | 2012-03-29 | 2012-06-08 | K-21801, XE801233 SS+20d |  | 47d | 0d |  | Equipment insulation [100 sqm]; Equipment insulation [1250 h] | 208.42 | 1250,00 | XV301233 | 1250 | 0 | 934 | 12 |  |  |  | LND | X | V | XV30 | 1233 | V | 12 | X | INS | LND | 1233 | VNZM |  | 2012-03-30 | E-13-03 |  |  |  |  |  |  |  |  |  |  |  |  |  |

Notes:
- XW501233: P3 Activity Log Info: Clarification Surface / Protection during Prefab

| ID | WBS | Activity | Type | Duration | Start | Finish | Predecessors | Complete | Remaining | Planned start | Planned finish | Total float | Free float | Constraint | Calendar | Resources | Cost | Actual cost | UDF_ELECTRICAL SEQUENCE | UDF_SAVE ACT ID | UDF_BUDGETED LABOR UNIT | UDF_ACTUAL LABOR UNIT | Department | Type of Work | Constr. Area | PMT-Area | PMT-Schedule Org | PMT-Phase | PMT-Respons. | WBS Phase | WBS Discipline | WBS Type of Work | WBS Objects | Russia WBS Discipline (Russia) | Russia Construction Area | Russia WBS Phase | IMS | UPT | Russia WBS Objects | Subcontractor | TB26 Ressource Budget | Inquiry/Order No | suspend date | resume date | UDF_CONTRACT INDICATOR | UDF_SELECT UPDATE PROGRESS | UDF_CHECK RESOURCE DATES | UDF_Concrete | UDF_BASELINE DEVELOPMENT | Check ResLoading | UDF_CHECK CRITICAL PATH | Filter | UDF_CHECK BASELINE | UDF_CONTRACT START DATE | UDF_CONTRACT FINISH DATE | UDF_CONTRACT ITEM | UDF_CONTRACT FINISH DATE REV1 | UDF_CONTRACT START DATE REV1 | geplanter Start | geplantes Ende | Zeigen/n. Zeigen | 4 week lookahead | Comments | Civil item |
| --- | --- | --- | --- | --- | --- | --- | --- | --- | --- | --- | --- | --- | --- | --- | --- | --- | --- | --- | --- | --- | --- | --- | --- | --- | --- | --- | --- | --- | --- | --- | --- | --- | --- | --- | --- | --- | --- | --- | --- | --- | --- | --- | --- | --- | --- | --- | --- | --- | --- | --- | --- | --- | --- | --- | --- | --- | --- | --- | --- | --- | --- | --- | --- | --- |
|  | 13 | **CA13 - Polymerisation Line 2** |  |  | 2008-09-24 | 2012-12-15 |  |  |  |  |  |  |  |  |  |  |  |  |  |  |  |  |  |  |  |  |  |  |  |  |  |  |  |  |  |  |  |  |  |  |  |  |  |  |  |  |  |  |  |  |  |  |  |  |  |  |  |  |  |  |  |  |  |  |
|  | 00 | **CA13 - General** |  |  | 2008-09-24 | 2012-12-15 |  |  |  |  |  |  |  |  |  |  |  |  |  |  |  |  |  |  |  |  |  |  |  |  |  |  |  |  |  |  |  |  |  |  |  |  |  |  |  |  |  |  |  |  |  |  |  |  |  |  |  |  |  |  |  |  |  |  |
|  | 0B | **General Activities** |  |  | 2012-10-10 | 2012-12-15 |  |  |  |  |  |  |  |  |  |  |  |  |  |  |  |  |  |  |  |  |  |  |  |  |  |  |  |  |  |  |  |  |  |  |  |  |  |  |  |  |  |  |  |  |  |  |  |  |  |  |  |  |  |  |  |  |  |  |
| X0101310 |  | CA13 General - Construction Completion | milestone | 0d | 2012-10-10 | 2012-10-10 | V-22221, HO-22206, HO-22204, P-22106, P-22103 A/B, XJ641301, XE911305, MI-22108 A/B, XE501322, XJ641332, XE601332, AG-22201, V-22223, HO-22207, PK-22211, XE911302, XR401304, XE701322, XE501332, MI-22202, MI-22101, AG-22101, XN601410, P-22101A/B, XR401321, XJ541321, MI-22107 A/B, XJ641322, XE911331, XJ541330, V-22224, XC801301, XE501304, V-22101, XJ641321, XE911325, P-22203, XE501330, XJ541332, XE911333, HO-22209, XC20130107, CY-22202, HO-22201, E-22203, E-22206, V-22103, XR401330, XE601330, XR401332, P-22104, MI-22106 A/B, XE601301, XJ541301, XE501321, XE601321, XE701321, XE911323, XR401322, P-22201A/B, XJ641330, HO-22203, HO-22202, V-22106, P-22108, P-22107, XN601301, XR401301, XJ521304, XH00132105, XJ541322, K-22201A/B, AG-22201-MI01, V-22222 (other project), HO-22208, HO-22205, MI-22104 A/B, XE501301, XE801304, XJ391301, XJ391321, XJ391322, XJ391330, XJ391332 |  |  |  |  | -102d | 9.5d |  | TB26 - 2 - Manuf and Delivy |  |  |  | XJ321321 | X0101310 | 0 | 0 | 934 | XNK | 13 | 200 | 200 | C | LND | X | 0B | X010 | 1300 | 0 | 13 | X | MC | LND | 1300 |  |  |  |  |  |  |  |  |  |  |  |  |  |  |  |  |  |  |  |  |  |  |  |  |  |
| X0101300 |  | CA13 General - Mechanical Completion | milestone | 0d | 2012-12-15 | 2012-12-15 | XC801301, XV301301 FF, XV301321, XJ801332, XV501304 FF, XJ801321, XV301322, XV501332, XE701322, XV301332, X0101310, XJ801301 FF, XV501321, XE601330, XE911333, XE911302, XV501301 FF, XC501322, XE911305, XH00132110, XE911325, XV501322, XV501330, XE911331, XE601301 FF, XH00132210, XE601322, XJ801322 FS+10d, XV301330, XJ801330, XC20130107, XE601332, P3J03S4 (other project) |  |  |  |  | -112.5d | 14d |  | TB26 - 2 - Manuf and Delivy |  |  |  | XJ321321 | X0101300 | 0 | 0 | 934 | XNK | 13 | 200 | 200 | C | LND | X | 0B | X010 | 1300 | 0 | 13 | X | MC | LND | 1300 |  |  |  |  |  |  |  |  |  |  |  |  |  |  |  |  |  |  |  |  |  |  |  |  |  |
|  | C | **Civil Work** |  |  | 2008-09-24 | 2012-07-19 |  |  |  |  |  |  |  |  |  |  |  |  |  |  |  |  |  |  |  |  |  |  |  |  |  |  |  |  |  |  |  |  |  |  |  |  |  |  |  |  |  |  |  |  |  |  |  |  |  |  |  |  |  |  |  |  |  |  |
| XC111300 |  | CA13 General - Excavation&Surface Prep U/I/O |  | 294d | 2008-09-24 A | 2009-09-30 A | XC111410 SS, XC111200 SS | 100% |  |  |  |  |  |  |  |  |  |  |  | XC111300 | 0 | 0 | 934 |  | 13 | 200 | 200 | C | UIO | X | C | XC11 | 1300 | C | 13 | X | EQ | LND | 1300 | MO11 |  |  |  |  |  |  |  |  |  |  |  |  |  |  |  |  |  |  |  |  |  |  |  |  |
| XC11130005 |  | CA13 General - Excavation outs.Reactor Structure |  | 20d | 2010-03-29 A | 2010-04-20 A | XC111300 | 100% |  |  |  |  |  |  |  | Excavation [5000 cbm]; Excavation [2500 h] | 200,000 | 200,000 |  | XC11130005 | 2500 | 2500 | 934 |  | 13 | 200 | 200 | C | MO02 | X | C | XC11 | 1300 | C | 10 | X | P | LND | 1010 | MO11 | 2500,00 | 999 |  |  |  |  |  |  |  |  |  |  |  |  |  |  |  |  |  |  |  |  |  |  |
| XC11130010 |  | CA13 General - SubBase (Gravel/Geogrid) for Concrete |  | 12d | 2010-04-21 A | 2010-05-06 A | XC11130005 | 100% |  | 2010-04-21 | 2010-05-05 |  |  |  |  | Sub Base for Concrete/Paving&Roads (Gravel) [10000 cbm]; Subbase for Concrete [10000 h] | 1,000,000 | 350,000 |  | XC11130010 | 10000 | 10000 | 934 |  | 13 | 200 | 200 | C | MO02 | X | C | XC11 | 1300 | C | 10 | X | P | LND | 1010 | MO11 | 10000,00 | 999 |  |  |  |  |  |  |  |  |  |  |  |  |  |  |  |  |  |  |  |  |  |  |
| XC151300 |  | CA13 General - Piling outs.Reactor Structure |  | 26d | 2010-05-06 A | 2010-06-04 A | EC151332 (other project) FF+10d, EC151304 (other project) FS+10d, XC11130005, EC151305 (other project) FS+10d, F2910, XC11130010, XC151301 SS, EC151322 (other project) FS+4d, XC111300, EC151321 (other project) FS+4d | 100% |  |  |  |  |  |  |  | Piles driven [331 pcs]; Piles driven [2482.5 h] | 99,300 | 99,300 |  | XC151300 | 2482,5 | 2482,5 | 934 |  | 13 | 200 | 200 | C | MO02 | X | C | XC15 | 1300 | C | 13 | X | P | LND | 1300 | MO11 | 2482,50 |  |  |  |  |  |  |  |  |  |  |  |  |  |  |  |  |  |  |  |  |  |  |  |
| XC191300 |  | CA13 General - Backfill |  | 226d | 2010-09-13 A | 2011-10-15 | XC911321 FF+20d, XC911332 FF+20d, XC911301 FF+20d, XC911322 FF+12d, XC911304 FF+10d, XC911330 FF+10d | 100% | 13d | 2010-09-13 | 2011-09-20 | -49d | 3d |  | TB26 - T - Construct-Winter-3 (Dec/Jan/Feb free) * | Backfill & Compaction [8000 cbm]; Backfill & Compaction [12000 h] | 720,000 | 286,143.41 |  | XC191300 | 12000 | 12000 | 934 |  | 13 | 200 | 200 | C | CiC | X | C | XC19 | 1300 | C | 13 | X | UG | LND | 1300 | MO11 | 12000,00 |  | 2010-11-01 | 2010-11-30 | UDF_G4 | 27.8. | x |  |  |  |  |  |  |  |  |  |  |  |  |  |  |  |  |  |
| XC301300 |  | CA13 General - UG Installation (incl. Precast Manholes) |  | 60d | 2011-10-20 | 2012-02-21 | XC20130410 FF+20d, XC300C10, XC310C00, P3C02D4 (other project) FS+20d, P3R02AS1 (other project), P3R02BS (other project), P3R02S1 (other project) FF, XC300C00 SS, XC201305 FF+20d, P3R02AS1 (other project) FF, P3S08S (other project) FF+30d, XC401322 FF+5d, P3R02S1 (other project), IMS-C-000070 FF, XC201301 SS+30d, XC401321 FF+20d, XC201332 FF+20d, P3R01S (other project) FF, EC301300 (other project), XC300C00 FS+10d, ER441300 (other project), XC191300 |  |  |  |  | -52d | 0d |  | TB26 - V - Construct-Winter partly * | Cast Iron U/G Piping [575 m]; Concrete Manholes [17 pcs]; Floor Drains / Catch Basins [2 pcs]; Fire water hydrants/monitors [3 pcs]; FRP U/G Piping [305 m]; Cast iron U/G piping [11500 h]; concrete manholes [4812 h]; floor drains / catch basins [62 h]; fire water hydrants/ monitors [187.5 h]; FRP U/G piping [3812 h] | 359,365.71 |  |  | XC301300 | 20373,5 | 0 | 934 |  | 13 | 200 | 200 | C | CiC | X | C | XC30 | 1300 | C | 13 | X | UG | LND | 1300 |  | 40750,00 |  |  |  |  |  |  | 1 | XC301300 | UG |  |  |  |  |  |  |  |  |  |  |  |  |  |  |
| XC301310 |  | CA13 General - UG Installation (incl. Precast Manholes) |  | 60d | 2012-03-02 | 2012-05-21 |  |  |  |  |  | 216.11d | 0d | start on or after 2012-03-02 | TB26 - V - Construct-Winter partly * | Cast Iron U/G Piping [575 m]; Concrete Manholes [18 pcs]; Floor Drains / Catch Basins [3 pcs]; Fire water hydrants/monitors [3 pcs]; FRP U/G Piping [305 m]; Cast iron U/G piping [11500 h]; concrete manholes [4813 h]; floor drains / catch basins [63 h]; fire water hydrants/ monitors [188 h]; FRP U/G piping [3813 h] | 371,365.71 |  |  | XC301300 | 20377 | 0 | 934 |  | 13 | 200 | 200 | C | CiC | X | C | XC30 | 1300 | C | 13 | X | UG | LND | 1300 |  | 40750,00 |  |  |  |  |  |  | 1 | XC301300 | UG | XC301300 |  |  |  |  |  |  |  |  |  |  |  |  |  |
| XC191305 |  | CA13 General - Backfill |  | 30d | 2012-03-12 | 2012-04-18 | XC301300 FS+10d |  |  |  |  | -16d | 0d |  | TB26 - T - Construct-Winter-3 (Dec/Jan/Feb free) * | Backfill & Compaction [8000 cbm]; Backfill & Compaction [12000 h] | 720,000 |  |  | XC191305 | 12000 | 0 | 934 |  | 13 | 200 | 200 | C | CiC | X | C | XC19 | 1300 | C | 13 | X | UG | LND | 1300 | MO11 | 24000,00 |  | 2010-11-01 | 2010-11-30 |  |  |  |  | XC301300 | X |  | 1 | x |  |  |  |  |  |  |  |  |  |  |  |
| XH601300 |  | CA13 General - Snow Melting System |  | 15d | 2012-04-19 | 2012-05-07 | XC191300 FF+20d, XC301300, XC191305, EC601300 (other project) FS+20d, XC191300 SS+20d, IMS-P-000100 FF, XH000000 FF |  |  |  |  | 45d | 0d |  |  |  |  |  |  | XH601300 | 17685 | 0 | 934 |  | 13 | 200 | 200 | C | CiC | X | H | XH00 | 1300 | H | 13 | X | PV | LND | 1300 | ARMO | 4300 |  |  |  |  |  |  | 1 | XC301300 |  |  |  | x |  |  |  |  |  |  |  |  |  |  |  |
| XC111196045 |  | CA13 General - Backfill |  | 30d | 2012-04-25 | 2012-06-01 | XC301310 FF+10d |  |  |  |  | 216.11d | 0d |  | TB26 - T - Construct-Winter-3 (Dec/Jan/Feb free) * | Backfill & Compaction [8000 cbm]; Backfill & Compaction [12000 h] | 720,000 |  |  | XC191305 | 12000 | 0 | 934 |  | 13 | 200 | 200 | C | CiC | X | C | XC19 | 1300 | C | 13 | X | UG | LND | 1300 | MO11 | 24000,00 |  | 2010-11-01 | 2010-11-30 |  |  |  |  | XC301300 | X |  | 1 | x |  |  |  |  |  |  |  |  |  |  |  |
| XC601300 |  | CA13 General - Paving inside / outside |  | 25d | 2012-05-08 | 2012-06-06 | XC191305 SS+20d, EC601300 (other project) FS+20d, XC191300 SS+20d, XC191300 FF+20d, XC191305 FF+20d, XH601300, XH000000 FF, IMS-P-000100 FF |  |  |  |  | 251.5d |  |  |  | Concrete paved areas & concrete Roads [2350 sqm]; Open ditches; Gravel [600 sqm]; Concrete paved areas & concrete roads [8812 h]; open ditches; Gravel [30 h] | 18,616.61 |  |  | XC601300 | 8842 | 0 | 934 |  | 13 | 200 | 200 | C | CiC | X | C | XC60 | 1300 | C | 13 | X | PV | LND | 1300 | MO11 | 17685,00 |  |  |  |  |  |  | 1 | XC301300 |  |  |  | x |  |  |  |  |  |  |  |  |  |  |  |
| XH601320 |  | CA13 General - Snow Melting System |  | 15d | 2012-06-01 | 2012-06-20 | XC301310, XC111196045 |  |  |  |  | 216.11d | 0d |  |  |  |  |  |  | XH601300 | 17685 | 0 | 934 |  | 13 | 200 | 200 | C | CiC | X | H | XH00 | 1300 | H | 13 | X | PV | LND | 1300 | ARMO | 4300 |  |  |  |  |  |  | 1 | XC301300 |  |  |  | x |  |  |  |  |  |  |  |  |  |  |  |
| XC111196065 |  | CA13 General - Paving inside / outside |  | 25d | 2012-06-20 | 2012-07-19 | XC111196045 SS+20d, XC111196045 FF+20d, XH601320 |  |  |  |  | 216.11d |  |  |  | Concrete paved areas & concrete Roads [2350 sqm]; Open ditches; Gravel [600 sqm]; Concrete paved areas & concrete roads [8813 h]; open ditches; Gravel [30 h] | 18,616.61 |  |  | XC601300 | 8843 | 0 | 934 |  | 13 | 200 | 200 | C | CiC | X | C | XC60 | 1300 | C | 13 | X | PV | LND | 1300 | MO11 | 17685,00 |  |  |  |  |  |  | 1 | XC301300 |  |  |  | x |  |  |  |  |  |  |  |  |  |  |  |
|  | E | **Electrical** |  |  | 2011-12-23 | 2012-06-02 |  |  |  |  |  |  |  |  |  |  |  |  |  |  |  |  |  |  |  |  |  |  |  |  |  |  |  |  |  |  |  |  |  |  |  |  |  |  |  |  |  |  |  |  |  |  |  |  |  |  |  |  |  |  |  |  |  |  |
| XE701300 |  | CA13 General - Install Lighting & Small Power |  | 80d | 2011-12-23 | 2012-04-03 | EE761300 (other project), XP341610 FS+50d, XJ421304 FF, XJ421332, EE76130010 (other project), XN601301 FS+6d, P3E09S (other project), EE76510110 (other project) |  |  |  |  | 254.5d | 0d |  |  | Cable Pulling [1200 m]; Lighting illuminates [170 pcs]; Cable pulling [600 h]; Lighting (iluminates) [1700 h] | 92,000 |  |  | XE701300 | 2300 | 0 | 934 |  | 13 | 200 | 200 | C | LND | X | E | XE70 | 1300 | E | 13 | X | EL | LND | 1300 | URMA | 2300,00 |  |  |  |  |  |  |  |  |  |  | x |  | 2011-05-10 | 2012-01-31 | E-16-03-01 | 2012-05-10 | 2011-08-15 |  |  |  |  |  |  |
| XE921300 |  | CA13 General - Install Fire Detection System |  | 50d | 2012-04-04 | 2012-06-02 | XN601301, XE701300 |  |  |  |  | 254.5d | 0d |  |  | Fire Detection System; Fire detection system |  |  |  | XE921300 | 0 | 0 | 934 |  | 13 | 200 | 200 | C | UIO | X | E | XE92 | 1300 | E | 13 | X | FGDS | LND | 1300 |  | 0,00 |  |  |  |  |  |  |  |  |  |  | x | x |  |  |  |  |  | 2012-02-17 | 2012-07-13 |  |  |  |  |
| XE961300 |  | CA13 General - Install Communication System |  | 50d | 2012-04-04 | 2012-06-02 | XE701300, XN601301, XE921300 SS, E3E1350 (other project) |  |  |  |  | 254.5d |  |  |  | Communication System |  |  |  | XE961300 | 0 | 0 | 934 |  | 13 | 200 | 200 | C | LND | X | E | XE96 | 1300 | E | 13 | X | CS | LND | 1300 |  | 0,00 |  |  |  |  |  |  |  |  |  |  | x | x |  |  |  |  |  | 2012-02-17 | 2012-07-13 |  |  |  |  |
|  | 01 | **CA13 - Reactor Structure** |  |  | 2010-03-29 | 2012-12-15 |  |  |  |  |  |  |  |  |  |  |  |  |  |  |  |  |  |  |  |  |  |  |  |  |  |  |  |  |  |  |  |  |  |  |  |  |  |  |  |  |  |  |  |  |  |  |  |  |  |  |  |  |  |  |  |  |  |  |
|  | C | **Civil Work** |  |  | 2010-03-29 | 2012-06-08 |  |  |  |  |  |  |  |  |  |  |  |  |  |  |  |  |  |  |  |  |  |  |  |  |  |  |  |  |  |  |  |  |  |  |  |  |  |  |  |  |  |  |  |  |  |  |  |  |  |  |  |  |  |  |  |  |  |  |
| XC111301 |  | CA13 ReactorStruc - Excavation |  | 20d | 2010-03-29 A | 2010-04-20 A | XC111300 | 100% |  |  |  |  |  |  |  | Excavation [13200 cbm]; Excavation [6600 h] | 528,000 | 528,000 |  | XC111301 | 6600 | 6600 | 934 |  | 13 | 200 | 200 | C | MO02 | X | C | XC11 | 1301 | C | 10 | X | P | LND | 1010 | MO11 | 6600,00 | 999 |  |  |  |  |  |  |  |  |  |  |  |  |  |  |  |  |  |  | C8 |  |  |  |
| XC11130110 |  | CA13 ReactorStruc - SubBase (Gravel/Geogrid) for Concrete |  | 12d | 2010-04-21 A | 2010-05-05 A | XC111301 | 100% |  |  |  |  |  |  |  | Sub Base for Concrete/Paving&Roads (Gravel) [1000 cbm]; Subbase for Concrete [1000 h] | 100,000 | 100,000 |  | XC11130110 | 1000 | 1000 | 934 |  | 13 | 200 | 200 | C | MO02 | X | C | XC11 | 1301 | C | 10 | X | P | LND | 1010 | MO11 | 1000,00 | 999 |  |  |  |  |  |  |  |  |  |  |  |  |  |  |  |  |  |  | C8 |  |  |  |
| XC151301 |  | CA13 ReactorStruc - Piling |  | 36d | 2010-05-06 A | 2010-06-16 A | XC111301 FS+5d, EC151301 (other project) FS+5d, XC11130110, F2910, XC151201 SS+6d | 100% |  |  |  |  |  |  |  | Piles driven [234 pcs]; Piles driven [1755 h] | 2,084.23 |  |  | XC151301 | 1755 | 1755 | 934 |  | 13 | 200 | 200 | C | MO02 | X | C | XC15 | 1301 | C | 13 | X | P | LND | 1301 | MO11 | 1755,00 |  |  |  |  |  |  |  |  |  |  |  |  |  |  |  |  |  |  |  | C8 |  |  |  |
| XC201300 |  | CA13 ReactorStruc - Concrete Works Base Plate |  | 35d | 2010-06-14 A | 2010-07-23 A | XC20120105 SS, EC45130105 (other project) FF, P3C02D1 (other project), EC28130105 (other project) FS+7d, XC151301 | 100% |  |  |  |  |  |  | TB26 - V - Construct-Winter partly * | Concrete works [1098 cbm]; Concrete works [32940 h] | 1,317,600 | 1,317,600 |  | XC201300 | 32940 | 32940 | 934 |  | 13 | 200 | 200 | C | MO03 | X | C | XC20 | 1301 | C | 13 | X | mai | LND | 1301 | MO11 | 32940,00 |  |  |  |  |  |  |  |  |  |  |  |  |  |  |  |  |  |  |  | C8 |  |  |  |
| XC201301 |  | CA13 ReactorStruc - Concrete Works Structure+6m |  | 68d | 2010-08-31 A | 2010-11-27 A | EC28130112 (other project) FF+20d, P3C02D2 (other project) FS+25d, EC45130105 (other project), EC28130110 (other project) FS+4d, XC201300 | 100% |  | 2010-08-31 | 2010-11-25 |  |  |  | TB26 - V - Construct-Winter partly * | Concrete works [440 cbm]; Concrete works [13200 h] | 32,061.64 |  |  | XC201301 | 13200 | 13200 | 934 |  | 13 | 200 | 200 | C | MO04 | X | C | XC20 | 1301 | C | 13 | X | OB | LND | 1301 | MO11 | 13200,00 |  |  |  |  |  |  |  |  |  |  |  |  |  |  |  |  |  |  |  | C8 |  |  |  |
| XC20130005 |  | CA13 ReactorStruc - Concrete Works Piperack Foundations |  | 122d | 2010-09-15 A | 2011-02-12 A | XC201300 FS+50d | 100% |  |  |  |  |  |  |  | Concrete works [50 cbm]; Concrete works [1500 h] | 41,980.2 |  |  | XC20130005 | 1500 | 1500 | 934 |  | 13 | 200 | 200 | C | MO03 | X | C | XC20 | 1301 | C | 13 | X | mai | LND | 1301 | MO11 | 1500,00 |  |  |  |  |  |  |  |  |  |  |  |  |  |  |  |  |  |  |  | C8 |  |  |  |
| XC20130115 |  | CA13 ReactorStruc SK1301 - Precast Concrete Elements |  | 74d | 2010-11-16 A | 2011-02-17 A | EC28130112 (other project) FS+5d, P3C02D2 (other project) | 100% |  |  |  |  |  |  |  |  |  |  |  | XC20130115 | 0 | 0 | 934 |  | 13 | 200 | 200 | C | MO04 | X | C | XC20 | 1301 | C | 12 | X | pre | LND | 1204 | MO11 |  |  |  |  |  |  |  |  |  |  |  |  |  |  |  |  |  |  |  |  |  | x |  |  |
| XC20130109 |  | CA13 ReactorStruc - Concrete Works Structure+6m finished | milestone | 0d | 2010-11-27 A | 2010-11-27 A | XC201301 FF | 100% |  | 2010-11-25 | 2010-11-25 |  |  |  | TB26 - V - Construct-Winter partly * |  |  |  |  | XC20130109 | 0 | 0 | 934 |  | 13 | 200 | 200 | C | MO04 | X | C | XC20 | 1301 | C | 12 | X | mai | LND | 1201 | MO11 |  |  |  |  |  |  |  |  |  |  |  |  |  |  |  |  |  |  |  |  |  |  |  |  |
| XC20130120 |  | CA13 ReactorStruc SK1301 - Erection Precast Elements (SK1301) |  | 10d | 2011-02-14 A | 2011-03-05 A | XC20130115 FS-7d, XC201301 FS+12d, XC20130005, XC20130115 SS+25d, XC20120120 SS | 100% |  | 2011-02-14 | 2011-03-04 |  |  |  | TB26 - V - Construct-Winter partly * | Precast Concrete Works [70 cbm]; Precast concrete works [175 h] | 7,000 | 7,000 |  | XC20130120 | 175 | 175 | 934 |  | 13 | 200 | 200 | C | MO04 | X | C | XC20 | 1301 | C | 12 | X | OB | LND | 1204 | MO11 | 175,00 |  |  |  |  |  |  |  |  |  |  |  |  |  |  |  |  |  |  |  |  | x | finished | Comp |
| XC181301 |  | CA13 ReactorStruc - Concrete Works Base Plate (Coating/Grouting) |  | 20d | 2012-04-04 | 2012-04-26 | XC201300, XR401301 |  |  |  |  | 53d | 0d |  | TB26 - V - Construct-Winter partly * | Concrete works [362 cbm]; Concrete works [10860 h] | 434,400 |  |  | XC181301 | 10860 | 0 | 934 |  | 13 | 200 | 200 | C | MO03 | X | C | XC20 | 1301 | C | 12 | X | mai | LND | 1201 | MO11 | 10860,00 |  |  |  |  |  |  |  |  |  |  | 1 |  |  |  |  |  |  |  |  | C8 |  |  |  |
| XC801301 |  | CA13 ReactorStruc SK1301/SK1300 - Fire Proofing |  | 45d | 2012-04-16 | 2012-06-08 | XN201301u FF+20d, XN201301l, IMS-C-000130 SS, IMS-C-000130 FF, IMS-C-000135 |  |  |  |  | 18d | 105d | start on or after 2012-04-16 | TB26 - T - Construct-Winter-3 (Dec/Jan/Feb free) * | Fire proofing [150 sqm]; Fire proofing [1125 h] | 23,362.57 |  |  | XC801301 | 937,5 | 0 | 934 |  | 13 | 200 | 200 | C | CiC | X | C | XC80 | 1301 | C | 13 | X | FP | LND | 1301 | KRILAK | 937,50 |  |  |  |  |  |  | 1 |  |  |  |  |  |  |  |  |  |  |  |  |  |  |  |  |
| XC20130107 |  | CA13 ReactorStruc - Concrete Works Base Plate finished | milestone | 0d | 2012-04-26 | 2012-04-26 | XC181301, XC201300 FF |  |  |  |  | 53d | 140d |  | TB26 - V - Construct-Winter partly * |  |  |  |  | XC20130107 | 0 | 0 | 934 |  | 13 | 200 | 200 | C | MO03 | X | C | XC20 | 1301 | C | 12 | X | mai | LND | 1201 | MO11 |  |  |  |  |  |  |  |  |  |  |  |  |  |  |  |  |  |  |  |  |  |  |  |  |

Notes:
- X0101310: UDF_PREDECESSOR: XJ641301, XE911305, XE501322, XJ641332, XE601332, XE911302, XE701322, XE501332
- X0101300: UDF_PREDECESSOR: XJ801332, XJ801321, XE701322, XJ801301, XE601330, XE911333, XE911302, XE911305, XE911325, XE911331, XE601301
- XC111300: P3 Activity Log Info: incl. Dewatering/Drainage
- XC151300: P3 Activity Log Info: 642 dp expected
- XC301300: P3 Activity Log Info: Clarification Prefab / Catch Basins/pulling pits
- XC301310: P3 Activity Log Info: Clarification Prefab / Catch Basins/pulling pits
- XE921300: Scope: CA13 Polymerization Line 2 / FDS - 49 external sensors / GDS - 26 external sensors / DS + SAME
- XE961300: Scope: CA13 Polymerization Line 2 / FDS - 49 external sensors / GDS - 26 external sensors / DS + SAME
- XC151301: P3 Activity Log Info: 94 bored piles d=120cm, 2/d/machine
- XC20130115: Current Status: 05.02.2011 (O.Siegel): Termin wird gehalten (MO11 am 04.02.2011) / 13.01.2011 (Oxana): laut Auskunft von Mostostroy sind ca. 40% fertig. / Endtermin wurde auf den 17.01.2011 verschoben.
- XC20130120: Current Status: 14.03.2011 (O.Siegel): die Pedestels sind alle fertig, jedoch noch nicht / ausgeschalt. 15-Mrz-11 als Ьbergabetermin an CSK bleibt. / 09.03.2011 (O.Siegel): die Pedestels werden frьhestens zum 15.03.2011 / fertiggestelt und kцnnen an die CSK ьbergeben werden (Info aus dem weekly / meeting). / 05.02.2011 (O.Siegel): Termin wird gehalten (MO11 am 04.02.2011) / 13.01.2011 (Oxana): zum 01.01.2011 wurden keine Arbeiten durchgefьhrt / (Angaben aus CPMR). Startdatum auf den 10.01.2011 verschoben und die Dauer von / 15 auf 10 Tage verkьrzt. Endtermin wird gehalten (Angaben von Mostostroy).
- XC801301: Current Status: 20110906 (O.Siegel): die Prioritдten fьr Fire Proofing: 17 - 3101 - / 1101. die restlichen CA werden in 2012 gefertigt / 20110530 (O.Siegel): die Vertragsverhandlung ist am 30.05.2011. Bis die / Vertragliche Detail geklдrt werden und die Firma MobilisierungsmaЯnahmen / getroffen hat, wird es Mitte Juli sein. / Scope: SK1300: / No. of beams/ columns: 14 (fire Resistance R120) / Length 24,77m; Weight: 925,46 kg; Surface Area 24,90 sqm / SK1301: / No. of beams/ columns: 16 (fire Resistance R120) / Length 54,03m; Weight: 10285,68 kg; Surface Area 122,7 / sqm

| ID | WBS | Activity | Type | Duration | Start | Finish | Predecessors | Complete | Remaining | Planned start | Planned finish | Total float | Free float | Constraint | Calendar | Resources | Cost | Actual cost | TB26 Ressource Budget | UDF_SAVE ACT ID | UDF_CHECK BASELINE | UDF_BUDGETED LABOR UNIT | UDF_ACTUAL LABOR UNIT | Department | Type of Work | Constr. Area | PMT-Area | PMT-Schedule Org | PMT-Phase | PMT-Respons. | Zeigen/n. Zeigen | WBS Phase | WBS Discipline | WBS Type of Work | WBS Objects | Russia WBS Discipline (Russia) | Russia Construction Area | Russia WBS Phase | IMS | UPT | Russia WBS Objects | UDF_CONTRACT START DATE | UDF_CONTRACT FINISH DATE | UDF_CONTRACT ITEM | TB26 Semantics | 4 week lookahead | Subcontractor | UDF_CONTRACT INDICATOR | UDF_SELECT UPDATE PROGRESS | UDF_CHECK RESOURCE DATES | UDF_COMMENTS | UDF_Weight (ton) | WEIGHT | UDF_LEVEL | UDF_PO No | UDF_TAG No | UDF_Object No | UDF_DELIVERY DATE PO | UDF_DELIVERY DATE DISPATCH PLANNED | UDF_DELIVERY DATE TO SITE PLANNED | UDF_DELIVERY DATE SITE NEED DATE | UDF_SHIPMENT No | UDF_SUPPLIER | Filter | UDF_DELIVERY DATE DISPATCH ACTUAL | Check ResLoading |
| --- | --- | --- | --- | --- | --- | --- | --- | --- | --- | --- | --- | --- | --- | --- | --- | --- | --- | --- | --- | --- | --- | --- | --- | --- | --- | --- | --- | --- | --- | --- | --- | --- | --- | --- | --- | --- | --- | --- | --- | --- | --- | --- | --- | --- | --- | --- | --- | --- | --- | --- | --- | --- | --- | --- | --- | --- | --- | --- | --- | --- | --- | --- | --- | --- | --- | --- |
|  | N | **Structural Steel** |  |  | 2011-03-07 | 2011-11-05 |  |  |  |  |  |  |  |  |  |  |  |  |  |  |  |  |  |  |  |  |  |  |  |  |  |  |  |  |  |  |  |  |  |  |  |  |  |  |  |  |  |  |  |  |  |  |  |  |  |  |  |  |  |  |  |  |  |  |  |  |
| XN701301 |  | CA13 ReactorStruc SK1301 - KMD Assy Drawings (lower part) | milestone | 0d | 2011-03-07 A | 2011-03-07 A |  | 100% |  |  |  |  |  | finish on 2011-03-05 | TB26 - V - Construct-Winter partly * |  |  |  | 22t | XN701301 | x | 0 | 0 | 934 | XNK | 13 | 200 | 200 | C | LND | KMD | X | N | XN05 | 1301 | N | 13 | X | SS | LND | 1301 |  |  |  |  |  |  |  |  |  |  |  |  |  |  |  |  |  |  |  |  |  |  |  |  |  |
| XN701300 |  | CA13 ReactorStruc SK1300 - KMD Assy Drawings | milestone | 0d | 2011-03-28 A | 2011-03-28 A |  | 100% |  |  |  |  |  | finish on or after 2011-03-23 | TB26 - V - Construct-Winter partly * |  |  |  | 22t | XN701300 | x | 0 | 0 | 934 | XNK | 13 | 200 | 200 | C | LND | KMD | X | N | XN05 | 1301 | N | 13 | X | SS | LND | 1300 |  |  |  |  |  |  |  |  |  |  |  |  |  |  |  |  |  |  |  |  |  |  |  |  |  |
| XN711300 |  | CA13 ReactorStruc SK1300 - Steel Deliveries | milestone | 0d | 2011-03-30 A | 2011-03-30 A |  | 100% |  |  |  |  |  | finish on 2011-03-30 | TB26 - 3 - Construction Normal 7days * CA17 |  |  |  | 22t | XN711300 |  | 0 | 0 | 934 | XNK | 13 | 200 | 200 | C | LND | SD | X | N | XN06 | 1301 | N | 13 | X | SS | LND | 1300 |  |  |  |  |  |  |  |  |  |  |  |  |  |  |  |  |  |  |  |  |  |  |  |  |  |
| XN731301 |  | CA13 ReactorStruc SK1301 - Steel Deliveries (upper part) | milestone | 0d | 2011-04-08 A | 2011-04-08 A |  | 100% |  |  |  |  |  | finish on 2011-04-08 | TB26 - 3 - Construction Normal 7days * CA17 |  |  |  | 22t | XN731301 |  | 0 | 0 | 934 | XNK | 13 | 200 | 200 | C | LND | SD | X | N | XN06 | 1301 | N | 13 | X | SS | LND | 1301 |  |  |  |  |  |  |  |  |  |  |  |  |  |  |  |  |  |  |  |  |  |  |  |  |  |
| XN721301 |  | CA13 ReactorStruc SK1301 - KMD Assy Drawings (upper part) | milestone | 0d | 2011-04-11 A | 2011-04-11 A |  | 100% |  |  |  |  |  | finish on or after 2011-04-11 | TB26 - V - Construct-Winter partly * |  |  |  | 22t | XN721301 | x | 0 | 0 | 934 | XNK | 13 | 200 | 200 | C | LND | KMD | X | N | XN05 | 1301 | N | 13 | X | SS | LND | 1301 |  |  |  |  |  |  |  |  |  |  |  |  |  |  |  |  |  |  |  |  |  |  |  |  |  |
| XN711301 |  | CA13 ReactorStruc SK1301 - Steel Deliveries (lower part) | milestone | 0d | 2011-04-12 A | 2011-04-12 A |  | 100% |  |  |  |  |  | finish on or after 2011-04-11 | TB26 - 3 - Construction Normal 7days * CA17 |  |  |  | 22t | XN711301 |  | 0 | 0 | 934 | XNK | 13 | 200 | 200 | C | LND | SD | X | N | XN06 | 1301 | N | 13 | X | SS | LND | 1301 |  |  |  |  |  |  |  |  |  |  |  |  |  |  |  |  |  |  |  |  |  |  |  |  |  |
| XN201301l |  | CA13 ReactorStruc SK1301 - Erection/Preassembly Primary Steel +30m (lower part) |  | 0d | 2011-04-19 A | 2011-06-27 A | XN201201l SS+6d, P3N02GN (other project), XC20130120 FF+10d, XN711301, XB30130110, XN701301, P3N012D (other project) FS+10d | 100% |  | 2011-06-25 | 2011-06-25 |  |  |  | TB26 - V - Construct-Winter partly * | Piperacks, Main structures [14577.5 h]; Piperacks, Main Structures [343 t] |  |  | 14577,50 | XN201301l |  | 14577,5 | 10752,5 | 934 | XNK | 13 | 200 | 200 | C | LND |  | X | N | XN20 | 1301 | N | 13 | X | SS | LND | 1301 | 2011-01-20 | 2011-04-10 | E-04-05 | t | x | ChSK |  |  |  |  |  |  |  |  |  |  |  |  |  |  |  |  |  |  |  |
| XN601301 |  | CA13 ReactorStruc SK1301/00 - Install Gratings |  | 89d | 2011-06-20 A | 2011-09-30 | PN691301 (other project) |  | 30d |  |  | -65d | 0d |  |  | Grating [2750 sqm]; Grating [10312.5 h] | 116,406.36 |  | 10312,50 | XN601301 |  | 10312,5 | 559 | 934 | XNK | 13 | 200 | 200 | C | LND |  | X | N | XN60 | 1301 | N | 13 | X | SS | LND | 1301 |  |  |  |  |  | ChSK | UDF_G4 | 27.8. | actual finish |  |  |  |  |  |  |  |  |  |  |  |  |  |  |  |  |
| XN201301u |  | CA13 ReactorStruc SK1301/00 - Erection/Preassembly Primary Steel +30m (upper part) |  | 82d | 2011-06-28 A | 2011-09-30 | XN201301l, AG-22201-MI01 SS+5d, XN721301, XN711300 FS+10d, XN731301 FS+10d, XC20C000 FF, XN701300, XN201201l SS+12d, XB30130110 |  | 30d |  |  | -124d | 0d |  |  | Piperacks, Main structures [14875 h]; Piperacks, Main Structures [350 t] | 20,191.88 |  | 14875,00 | XN201301u |  | 14875 | 0 | 934 | XNK | 13 | 200 | 200 | C | LND |  | X | N | XN20 | 1301 | N | 13 | X | SS | LND | 1301 | 2011-01-20 | 2011-04-10 | E-04-05 | t |  | ChSK | UDF_G4 | 27.8. | actual finish |  |  |  |  |  |  |  |  |  |  |  |  |  |  |  |  |
| XN401301 |  | CA13 ReactorStruc SK1301/00 - Install Railing, Ladders |  | 59d | 2011-07-25 A | 2011-09-30 | XN201301l SS+15d |  | 30d |  |  | -4d | 454.5d |  |  | Ladders & platforms [31 t]; Ladders & platforms [3100 h] | 1,345.14 |  | 3100,00 | XN401301 |  | 3100 | 0 | 934 | XNK | 13 | 200 | 200 | C | LND |  | X | N | XN40 | 1301 | N | 13 | X | SS | LND | 1301 |  |  |  |  |  | ChSK |  | 27.8. | x |  |  |  |  |  |  |  |  |  |  |  |  |  |  |  |  |
| XN251301 |  | CA13 ReactorStruc SK1301/00 - Installation fireproof castables |  | 10d | 2011-09-22 | 2011-10-03 | XN201301l FS+25d, XN201301u FF+2d |  |  |  |  | -62d | 3d |  |  |  |  |  | 704 | XN251301 |  | 0 | 0 | 934 | XNK | 13 | 200 | 200 | C | LND |  | X | N | XN20 | 1301 | N | 13 | X | SS | LND | 1301 |  |  |  | t |  | MO11 | UDF_G4 |  |  | action by MO11 |  |  |  |  |  |  |  |  |  |  |  |  |  |  |  |
| XN801301 |  | CA13 ReactorStruc SK1301/00 - Install Cladding |  | 30d | 2011-10-01 | 2011-11-05 | EN801301 (other project), XN201301u, XN201301l |  |  |  |  | -24d | 100d |  |  | Cladding [620 sqm]; Cladding [3100 h] | 665.18 |  | 3100,00 | XN801301 |  | 3100 | 0 | 934 | XNK | 13 | 200 | 200 | C | LND |  | X | N | XN80 | 1301 | N | 13 | X | SS | LND | 1301 |  |  |  |  |  | ChSK |  |  |  |  |  |  |  |  |  |  |  |  |  |  |  |  |  |  |  |
|  | H | **HVAC** |  |  |  |  |  |  |  |  |  |  |  |  |  |  |  |  |  |  |  |  |  |  |  |  |  |  |  |  |  |  |  |  |  |  |  |  |  |  |  |  |  |  |  |  |  |  |  |  |  |  |  |  |  |  |  |  |  |  |  |  |  |  |  |  |
|  | U | **Package Units** |  |  |  |  |  |  |  |  |  |  |  |  |  |  |  |  |  |  |  |  |  |  |  |  |  |  |  |  |  |  |  |  |  |  |  |  |  |  |  |  |  |  |  |  |  |  |  |  |  |  |  |  |  |  |  |  |  |  |  |  |  |  |  |  |
|  | B | **Mechanical - Stationary Equipment** |  |  | 2010-11-30 | 2012-05-07 |  |  |  |  |  |  |  |  |  |  |  |  |  |  |  |  |  |  |  |  |  |  |  |  |  |  |  |  |  |  |  |  |  |  |  |  |  |  |  |  |  |  |  |  |  |  |  |  |  |  |  |  |  |  |  |  |  |  |  |  |
| XN001301 |  | CA13 ReactorStruc SK1301 - Ready for Install Reactor | milestone | 0d | 2010-11-30 A | 2010-11-30 A | XC201301 FF+6d | 100% |  |  |  |  |  |  |  |  |  |  |  | XN001301 |  | 0 | 0 | 934 | XNK | 13 | 200 | 200 | C | CiC | C8 | X | B | X000 | 1301 | C | 13 | X | SS | LND | 1301 | 2010-12-10 | 2010-12-20 | E-08-01-01 |  |  | VNZM |  |  |  |  |  |  |  |  |  |  |  |  |  |  |  |  |  |  |  |
| XB30130115 |  | CA13 ReactorStruc - Crane Demobilisation |  | 4d | 2010-12-01 A | 2010-12-04 A | XB30130110, XB30120110, XB30130105 | 100% |  |  |  |  |  |  |  |  |  |  |  | XB30130115 |  | 0 | 0 | 934 | XBB | 13 | 200 | 200 | C | LND |  | X | B | XB30 | 1301 | B | 12 | X | HL | LND | 1201 | 2010-12-10 | 2010-12-20 | E-08-01-01 |  |  | VNZM |  |  |  |  |  |  |  |  |  |  |  |  |  |  |  |  |  |  |  |
| XB30130105 |  | CA13 ReactorStruc - Crane Mobilisation Reactor |  | 6d | 2010-12-06 A | 2010-12-13 A | XB30120105 FF | 100% |  | 2010-12-06 | 2010-12-11 |  |  |  |  |  |  |  |  | XB30130105 |  | 0 | 0 | 934 | XBB | 13 | 200 | 200 | C | LND | C8 | X | B | XB30 | 1301 | B | 12 | X | HL | LND | 1201 | 2010-12-10 | 2010-12-20 | E-08-01-01 |  |  | VNZM |  |  |  |  |  |  |  |  |  |  |  |  |  |  |  |  |  |  |  |
| R-22201 |  | REACTOR |  | 4d | 2010-12-10 A | 2010-12-14 A | XB30130110 SS | 100% |  |  |  |  |  |  |  | Static Equipment > 10 tons [255.5 t]; Static equipment >10t [19185.5 h] | 766,500 | 766,500 | 19162,50 | R-22201 |  | 19185,5 | 19185,5 |  |  | 13 |  |  |  |  | EQ | X | B |  | 1301 |  |  |  |  |  |  |  |  |  |  |  | VNZM |  |  |  |  | 256 | 256000 | concrete +6.90 | 2 DC 844 / 9 | R-22201 | SK1301 | 2010-05-04 | 2010-06-16 | 2010-08-15 | 2010-09-30 | 1100 | Coek |  |  |  |
| V-22201 |  | REACTOR OVERHEAD SEPARATOR |  | 1d | 2010-12-10 A | 2010-12-14 A |  | 100% |  | 2011-09-19 | 2011-09-19 |  |  | start on or after 2011-09-19 |  | Static Equipment > 10 tons [49.3 t]; Static equipment >10t [3675 h] | 147,900 | 147,000 | 3675,00 | V-22201 |  | 3675 | 0 |  |  | 13 |  |  |  |  | EQ | X | B |  | 1301 |  |  |  |  |  |  |  |  |  |  |  | VNZM |  |  |  |  | 49 | 49000 | concrete +9.00 | 2 DC 8500/ 3 | V-22201 | SK1301 | 2010-05-04 | 2010-05-04 | 2010-09-01 | 2010-09-01 | 4000 | Wonil | 1 | 2010-07-05 | X |
| XB30130110 |  | CA13 ReactorStruc - Heavy Lift Reactor w. Agitators |  | 4d | 2010-12-10 A | 2010-12-14 A | P3ALL1S2 (other project) FS+6d, XN001301, ER291300 (other project), XN001301 FF, XC20130109 | 100% |  |  |  |  |  |  |  |  |  |  | 291 | XB30130110 |  | 0 | 0 | 934 | XBB | 13 | 200 | 200 | C | LND | C8 | X | B | XB30 | 1301 | B | 13 | X | HL | LND | 1301 | 2010-12-10 | 2010-12-20 | E-08-01-01 |  |  | VNZM |  |  |  |  |  |  |  |  |  |  |  |  |  |  |  |  |  |  |  |
| XB001301 |  | CA13 ReactorStruc - Install Static Eqpt | level of effort | 329d | 2011-05-26 A | 2012-05-07 | PK-22211 SS, E-22206 SS, V-22222 (other project) SS, V-22224 SS, HO-22203 FF, CY-22202 FF, HO-22201 FF, V-22222 (other project) FF, MI-22202 FF, HO-22204 SS, HO-22209 SS, HO-22208 SS, HO-22205 FF, HO-22201 SS, HO-22204 FF, PK-22211 FF, E-22203 FF, E-22206 FF, V-22221 SS, V-22223 SS, V-22223 FF, HO-22206 SS, AG-22201 SS, AG-22201 FF, V-22221 FF, HO-22202 FF, HO-22202 SS, HO-22209 FF, HO-22208 FF, CY-22202 SS, E-22203 SS, V-22224 FF, MI-22202 SS, HO-22203 SS, HO-22206 FF, HO-22205 SS |  | 208d | 2011-05-26 | 2012-06-27 | -58d | 0d |  |  |  |  |  | 114 | XB001301 |  | 0 | 0 | 934 | XBB | 13 | 200 | 200 | C | LND |  | X | B | XB00 | 1301 | B | 13 | X | EQ | LND | 1301 | 2011-02-25 | 2011-05-15 | E-08-01-09 |  |  | VNZM | UDF_G4 | 27.8. |  |  |  |  |  |  |  | SK1301 |  |  |  |  |  |  |  |  |  |
| E-22206 |  | REACTOR OVERHEAD CONDENSER |  | 1d | 2011-06-24 A | 2011-06-24 A | XN201301l, P3A04S2 (other project), E-21206, AG-22201-MI01, XN201301u SS+12d | 100% |  |  |  |  |  |  |  | Static Equipment > 10 tons [64.7 t]; Static equipment >10t [4852 h] | 194,100 | 194,100 | 4875,00 | E-22206 |  | 4852 | 4852 |  |  | 13 |  |  |  |  | EQ | X | B |  | 1301 |  |  |  |  |  |  |  |  |  |  |  | VNZM |  |  |  |  | 64,7 | 64700 | structure +19.80 | 2 DC 9110 | E-22206 | SK1301 | 2010-10-02 | 2010-11-23 | 2010-12-15 | 2011-02-10 | 1225 | W. Tosto Linde Impianti |  |  |  |
| HO-22201 |  | OVERHEAD TRAVELLING CRANE (over Gear-Unit) |  | 5d | 2011-10-01 | 2011-10-06 | ER291300 (other project), XN201301u, P3A12S5 (other project), XN201301l |  |  |  |  | -39d | 45d |  |  | Static Equipment < 10 tons [6.7 t]; Static equipment < 10t [670 h] | 26,800 |  | 670,00 | HO-22201 | x | 670 | 0 |  |  | 13 |  |  |  |  | EQ | X | B |  | 1301 |  |  |  |  |  |  |  |  |  |  |  | VNZM |  |  |  |  | 6,7 | 6700 | structure +15.365 |  | HO-22201 | SK1301 |  | 2011-01-09 |  | 2011-02-01 |  |  |  |  |  |
| E-22203 |  | REACTOR START-UP GAS HEATER |  | 20d | 2011-10-10 | 2011-11-01 | P3A06S2 (other project), XN201301u, ER291300 (other project) |  |  |  |  | -71d | 0d |  |  | Static Equipment < 10 tons [1.9 t]; Static equipment < 10t [190 h] | 7,600 |  | 190,00 | E-22203 |  | 190 | 0 |  |  | 13 |  |  |  |  | EQ | X | B |  | 1301 |  |  |  |  |  |  |  |  |  |  |  | VNZM |  |  |  |  | 1,9 | 1900 | concrete +2.250 | 2 DD 8530 | E-22203 | SK1301 | 2010-10-02 | 2010-11-30 | 2011-02-10 | 2011-02-10 |  | Linde E. India |  |  |  |
| CY-22202 |  | FIRST REACTOR OFFGAS CYCLONE |  | 10d | 2011-11-02 | 2011-11-14 | AG-21201-MI01, E-22203, V-22223, XN601301, V-22201, V-22222 (other project), R-22201, V-22221, XN201301u, AG-22201-MI01, ER291300 (other project) |  |  |  |  | -71d | 13d |  |  | Static Equipment < 10 tons [7.17 t]; Static equipment < 10t [717 h] | 28,680 |  | 717,00 | CY-22202 | diff name in cb | 717 | 0 |  |  | 13 |  |  |  |  | EQ | X | B |  | 1301 |  |  |  |  |  |  |  |  |  |  |  | VNZM |  |  |  |  | 7,17 | 7170 | structure +26.00 | 2 DC 859 | CY-22202 | SK1301 | 2010-06-30 | 2010-10-01 | 2010-11-01 | 2011-02-10 | 1103 | Facet |  |  |  |

Notes:
- XN711300: Scope: 09.02.2011: weight: 25 ton - Mrz 25 ton
- XN731301: Scope: 09.02.2011: weight: 300 ton - Jan 50ton; Feb 50 ton; Mrz 150 / ton; Apr 50 ton
- XN711301: Scope: 09.02.2011: weight: 350 ton - Jan 90ton; Feb 100 ton; Mrz 160 / ton
- XN601301: Current Status: 17.05.2011 (O.Siegel): zur Zeit / wurden keine Gratings gelifert.
- XN401301: Current Status: 17.05.2011 (O.Siegel): zur Zeit / wurden keine Railing and Ladders gelifert.
- R-22201: UDF_PACKAGE: ALL1 REACTORS WITH AGITATORS R-21-/22201)
- V-22201: UDF_PACKAGE: ALL2 PURGE COLUMNS / REACTOR OVERHEAD SEPARATORS (C-21-/22304, V-21-/22304)
- E-22206: UDF_PACKAGE: A04A REACTOR OVERHEAD CONDENSERS (E-21-/22206)
- HO-22201: UDF_PACKAGE: A12 OVERHEAD CRANES / TROLLEYS (incl. in Civil Subcontract)
- E-22203: UDF_PACKAGE: A06 R.START-UP GAS HEATER/STEAM CONDENSER (E-21-/22203/21901)
- CY-22202: Current Status: 110803 (WL): Delete Pred. P-22201A/B REACTOR QUENCH LIQUID PUMPS / UDF_PACKAGE: A05 OFFGAS CYCLONE, RECEIVER & TRANSITION PIECES (CY-21-/22202)

| ID | WBS | Activity | Type | Duration | Start | Finish | Predecessors | Complete | Remaining | Total float | Free float | Calendar | Resources | Cost | Actual cost | TB26 Ressource Budget | UDF_CONTRACT START DATE | UDF_CONTRACT FINISH DATE | UDF_CONTRACT ITEM | UDF_SAVE ACT ID | UDF_BUDGETED LABOR UNIT | UDF_ACTUAL LABOR UNIT | Department | Type of Work | Constr. Area | PMT-Area | PMT-Schedule Org | PMT-Phase | PMT-Respons. | WBS Phase | WBS Discipline | WBS Type of Work | WBS Objects | Russia WBS Discipline (Russia) | Russia Construction Area | Russia WBS Phase | IMS | UPT | Russia WBS Objects | Subcontractor | UDF_CONTRACT INDICATOR | UDF_CHECK CRITICAL PATH | UDF_SELECT UPDATE PROGRESS | UDF_CHECK RESOURCE DATES | UDF_PLANNED START | UDF_COMMENTS_0827 | UDF_PLANNED FINISH | TB26 Semantics | TB26 Material Res Values | UDF_ELECTRICAL START | UDF_ELECTRICAL FINISH | UDF_CONTRACT FINISH DATE REV1 | UDF_CONTRACT START DATE REV1 | UDF_CHECK BASELINE | UDF_Vendor Representatives | UDF_PENALIZED FINISH |
| --- | --- | --- | --- | --- | --- | --- | --- | --- | --- | --- | --- | --- | --- | --- | --- | --- | --- | --- | --- | --- | --- | --- | --- | --- | --- | --- | --- | --- | --- | --- | --- | --- | --- | --- | --- | --- | --- | --- | --- | --- | --- | --- | --- | --- | --- | --- | --- | --- | --- | --- | --- | --- | --- | --- | --- | --- |
|  | M | **Mechanical - Rotating Equipment** |  |  | 2011-05-25 | 2011-06-11 |  |  |  |  |  |  |  |  |  |  |  |  |  |  |  |  |  |  |  |  |  |  |  |  |  |  |  |  |  |  |  |  |  |  |  |  |  |  |  |  |  |  |  |  |  |  |  |  |  |  |
| XM001301 |  | CA13 ReactorStruc - Install Rotating Eqpt | level of effort | 16d | 2011-05-25 A | 2011-06-11 A | AG-22201-MI01 FF, AG-22201-MI01 SS | 100% |  |  |  |  |  |  |  | 32 | 2011-02-25 | 2011-05-15 | E-08-01-09 | XM001301 | 0 | 0 | 934 | XBB | 13 | 200 | 200 | C | LND | X | M | XM00 | 1301 | M | 13 | X | EQ | LND | 1301 | VNZM |  |  |  |  |  |  |  |  |  |  |  |  |  |  |  |  |
|  | R | **Piping** |  |  | 2011-02-26 | 2012-05-10 |  |  |  |  |  |  |  |  |  |  |  |  |  |  |  |  |  |  |  |  |  |  |  |  |  |  |  |  |  |  |  |  |  |  |  |  |  |  |  |  |  |  |  |  |  |  |  |  |  |  |
| XR201301 |  | CA13 ReactorStruc SK1301 - Piping Prefabrication |  | 184d | 2011-02-26 A | 2011-10-03 | EL1040 (other project) FF+20d, P3R06S (other project) FS-18d, P3R06DS (other project) FS-18d, ER491301 (other project) SS+18d, XR400C20 SF |  | 32d | -94d | 452.5d |  | A/G piping prefabrication [6350 Fpi]; A/G Piping (Prefab) [23812.5 h] | 22,231.77 |  | 23812,50 |  |  |  | XR201301 | 23812,5 | 6234 | 934 |  | 13 | 200 | 200 | C | LND | X | R | XR20 | 1301 | R | 13 | X | PRP | LND | 1301 | VNZM | UDF_G4 | Pruefen wg Materiallieferung | 27.8. | x |  |  |  |  |  |  |  |  |  |  |  |  |
| XR401301 |  | CA13 ReactorStruc SK1301 - Piping Installation |  | 150d | 2011-10-01 | 2012-04-03 | P3R03AS1 (other project) FF+20d, P3R04S1 (other project) FF+20d, P3J02AS (other project), XN601201 SS+30d, E-22206, AG-22201, P3R07AS1 (other project), P3J02S (other project) FF+20d, P3J04IS (other project) FF+20d, P3S02S (other project) FF+20d, P3R07AS (other project), P3R03BS1 (other project) FF+20d, P3R07BS (other project) FF+30d, P3R04AS (other project), P3S01S (other project) FF+20d, P3J02CS (other project), AG-22201-MI01 SS+12d, P3J02DS (other project) FF+20d, P3J04CS1 (other project), XN801301 FF+20d, XR201301 SS+40d, P3A25S (other project) FF+20d, P3R09BS (other project) FF+20d, P3R04S (other project) FF+20d, P3J01AS (other project), P3J01S (other project), XN201301u |  |  | -124d | 0d |  | A/G piping field installation [7750 Fpi]; Control & Shut-off valves [106 pcs]; A/G Piping (Field) [48437.5 h]; Install Control & Shut-off Valves [556.5 h]; Deluge Piping [2800 Fpi]; Deluge piping [17500 h] | 801,298.07 |  | 66494,00 | 2011-01-20 |  | E-06-03-04 | XR401301 | 66494 | 0 | 934 |  | 13 | 200 | 200 | C | LND | X | R | XR40 | 1301 | R | 13 | X | PI | LND | 1301 | VNZM |  |  |  |  | 2011-03-30 | depending on bridge to 5104 |  |  |  |  |  |  |  |  |  |  |
| XR601301 |  | CA13 ReactorStruc SK1301 - Piping Pressure Tests |  | 90d | 2012-01-11 | 2012-04-26 | X0300020, XR605103 FF+20d, XR401301 FF+20d |  |  | -124d | 0d |  |  |  |  | 1764 |  |  | E-06-03-04 | XR601301 | 0 | 0 | 934 |  | 13 | 200 | 200 | C | LND | X | R | XR60 | 1301 | R | 13 | X | HY | LND | 1301 | VNZM |  |  |  |  |  |  |  |  |  |  |  |  |  |  |  |  |
| XR801301 |  | CA13 ReactorStruc SK1301 - Piping Reinstatement |  | 40d | 2012-03-23 | 2012-05-10 | XR601301 FF+10d, IMS-C-000360 FF |  |  | -124d | 0d |  |  |  |  | 882 |  | 2011-11-30 | E-06-03-04 | XR801301 | 0 | 0 | 934 |  | 13 | 200 | 200 | C | LND | X | R | XR80 | 1301 | R | 13 | X | PI | LND | 1301 | VNZM |  |  |  |  |  |  | 2012-02-11 |  |  |  |  |  |  |  |  |  |
|  | E | **Electrical** |  |  | 2010-06-21 | 2012-09-12 |  |  |  |  |  |  |  |  |  |  |  |  |  |  |  |  |  |  |  |  |  |  |  |  |  |  |  |  |  |  |  |  |  |  |  |  |  |  |  |  |  |  |  |  |  |  |  |  |  |  |
| XC911301 |  | CA13 ReactorStruc - Install Earthing Sys_CIVIL |  | 36d | 2010-06-21 A | 2010-07-31 A | XC201300 SS, EE901301 (other project) | 100% |  |  |  |  | Grounding & Lightning [240 pcs]; Grounding & Lightning [2700 h] | 108,000 | 108,000 | 2700,00 |  |  |  | XC911301 | 2700 | 2700 | 934 |  | 13 | 200 | 200 | C | LND | X | C | XE91 | 1301 | C | 13 | X | EA | LND | 1301 | MO11 |  |  |  |  |  |  |  |  |  |  |  |  |  |  |  |  |
| XE401301 |  | CA13 ReactorStruc - Install Cable Trays (Start with Pipe Rack 1301) |  | 70d | 2011-10-07 | 2011-12-28 | EE46510120 (other project) FF, XE405104 SS+15d, XN601301 FS+5d, XN201301u, EE46130110 (other project), XN251301 |  |  | -65d | 29d |  | Cable trays/conduits [880 m]; Cable trays [2640 h] | 105,600 |  | 2640,00 | 2011-05-20 | 2011-07-20 | E-15-01-08 | XE401301 | 2640 | 0 | 934 |  | 13 | 200 | 200 | C | LND | X | E | XE40 | 1301 | E | 13 | X | EL | LND | 1301 | URMA | UDF_G3 |  |  |  |  |  |  | m | 1450 | 2011-07-27 | 2011-10-15 | 2011-11-10 | 2011-07-11 | x |  |  |
| XE801301 |  | CA13 ReactorStruc - Install Heat Tracing |  | 100d | 2012-05-04 | 2012-08-30 | MI-22202, E-22203, AG-22201, E3E1950 (other project), PK-22211, XW501301 SS+15d, AG-22201-MI01 SS+40d, P3E19S (other project), CY-22202, C-21801, XR401301 SS+40d, XR601301 FF+45d |  |  | -45d | 0d | TB26 - V - Construct-Winter partly * | Electrical Heat Tracing [2300 m]; Electrical heat tracing [1150 h] | 46,000 |  | 1150,00 | 2011-06-20 | 2012-03-20 | E-16-04-01 | XE801301 | 1150 | 0 | 934 |  | 13 | 200 | 200 | C | LND | X | E | XE80 | 1301 | E | 13 | X | HT | LND | 1301 | URMA | UDF_G3 |  |  |  |  | to be installed later |  |  |  |  |  | 2012-06-30 | 2011-09-15 |  | 005 |  |
| XE341301 |  | CA13 ReactorStruc - Install Local Operation Panels |  | 50d | 2012-05-08 | 2012-07-06 | XE401301, XJ421301, EE46130110 (other project), XR401301 SS+70d, AG-22201, CY-22202, E-22203, E-22206, HO-22201, HO-22202, HO-22203, HO-22204, HO-22205, HO-22206, HO-22208, HO-22209, MI-22202, PK-22211, R-22201, V-22201, V-22221, V-22222, V-22223, V-22224, AG-22201-MI01 |  |  | -58d | 37.5d |  | Field Panels [14 pcs]; Field panels [280 h] | 11,200 |  | 280,00 | 2011-06-10 | 2011-10-30 | E-16-07-04 | XE341301 | 280 | 0 | 934 |  | 13 | 200 | 200 | C | LND | X | E | XE34 | 1301 | E | 13 | X | EL | LND | 1301 | URMA | UDF_G3 |  |  |  |  | to be installed later |  |  |  |  |  | 2012-05-30 | 2011-07-20 |  |  |  |
| XE911302 |  | CA13 ReactorStruc - Install Earthing Sys_E/I |  | 20d | 2012-05-08 | 2012-05-31 | XN201301u, AG-22201, CY-22202, E-22203, E-22206, HO-22201, HO-22202, HO-22203, HO-22204, HO-22205, HO-22206, HO-22208, HO-22209, MI-22202, PK-22211, R-22201, V-22201, V-22221, V-22222, V-22223, V-22224, AG-22201-MI01 |  |  | 25d | 112d |  |  |  |  | 270 | 2011-06-10 | 2011-10-30 | E-16-07-04 | XE911302 | 0 | 0 | 934 |  | 13 | 200 | 200 | C | LND | X | E | XE91 | 1301 | E | 13 | X | EA | LND | 1301 | URMA | UDF_G3 |  |  |  |  |  |  |  |  |  |  | 2012-05-30 | 2011-07-20 |  |  |  |
| XE501301 |  | CA13 ReactorStruc - Cable Pulling Electric |  | 60d | 2012-06-09 | 2012-08-20 | P3E15CS (other project), EE561301 (other project), P3E15BS (other project), XE505103 SS+10d, XE500C01, XE401301, P3E15AS (other project), XE505102 SS+10d, XE505401 SS+15d |  |  | -95.5d | 0d | TB26 - V - Construct-Winter partly * | Cable Pulling [14400 m]; Cable pulling [7200 h] | 288,000 |  | 7200,00 | 2011-05-20 | 2012-02-10 | E-16-01-01 | XE501301 | 7200 | 0 | 934 |  | 13 | 200 | 200 | C | LND | X | E | XE50 | 1301 | E | 13 | X | EL | LND | 1301 | URMA | UDF_G3 |  |  |  |  |  |  | m | 14900 | 2011-09-23 | 2012-03-14 | 2012-07-01 | 2011-10-01 |  |  |  |
| XE601301 |  | CA13 ReactorStruc - Cable Termination & Testing |  | 50d | 2012-07-16 | 2012-09-12 | IMS-C-000260 FF, IMS-C-000390 FF, XE501301 FF+20d, XE341301 FF+20d, AG-22201, CY-22202, E-22203, E-22206, HO-22201, HO-22202, HO-22203, HO-22204, HO-22205, HO-22206, HO-22208, HO-22209, MI-22202, PK-22211, R-22201, V-22201, V-22221, V-22222, V-22223, V-22224, AG-22201-MI01 |  |  | -95.5d | 0d |  | Cable connecting [300 pcs]; Cable connecting [750 h] | 30,000 |  | 750,00 | 2011-04-20 | 2011-11-30 | E-16-02-01 | XE601301 | 750 | 0 | 934 |  | 13 | 200 | 200 | C | LND | X | E | XE60 | 1301 | E | 13 | X | ET | LND | 1301 | URMA | UDF_G3 |  |  |  |  |  |  |  |  |  |  | 2012-08-14 | 2011-12-10 |  |  |  |
|  | J | **Instrumentation** |  |  | 2011-11-30 | 2012-12-15 |  |  |  |  |  |  |  |  |  |  |  |  |  |  |  |  |  |  |  |  |  |  |  |  |  |  |  |  |  |  |  |  |  |  |  |  |  |  |  |  |  |  |  |  |  |  |  |  |  |  |
| XJ321301 |  | CA13 ReactorStruc - Install Junction Boxes (Start with Pipe Rack 1301) |  | 40d | 2011-11-30 | 2012-01-21 | EJ321301 (other project), P3J06ES (other project) FS+14d, EJ32171005 (other project), P3J06FS (other project), XR401301 FS-100d, AG-22201, CY-22202, E-22203, E-22206, HO-22201, HO-22202, HO-22203, HO-22204, HO-22205, HO-22206, HO-22208, HO-22209, MI-22202, PK-22211, R-22201, V-22201, V-22221, V-22222, V-22223, AG-22201-MI01 |  |  | -53d | 15d |  | Junction Boxes/Cabinets/Panels [67 pcs]; Install Junction Boxes/ Cabinets/ Panels [1675 h] | 67,000 |  | 1675,00 | 2011-06-10 | 2012-04-10 | E-17-04-04 | XJ321301 | 1675 | 0 | 934 |  | 13 | 200 | 200 | C | LND | X | J | XJ32 | 1301 | J | 13 | X | IN | LND | 1301 | URMA | UDF_G3 |  |  |  |  | to be installed later |  |  |  |  |  | 2012-07-05 | 2011-09-10 | x |  |  |
| XJ301301 |  | CA13 ReactorStruc - Install Field Instruments |  | 80d | 2011-12-26 | 2012-05-10 | P3J05S (other project), P3J04BS (other project), EJ360010 (other project), P3J07CS (other project), EJ361301 (other project), P3J03S2 (other project) FF, XR401301 SS+70d, P3J04AS (other project), P3J07BS (other project), XR801301 FF, AG-22201, CY-22202, E-22203, E-22206, HO-22201, HO-22202, HO-22203, HO-22204, HO-22205, HO-22206, HO-22208, HO-22209, MI-22202, PK-22211, R-22201, V-22201, V-22221, V-22222, V-22223, AG-22201-MI01 |  |  | -87d | 0d | TB26 - V - Construct-Winter partly * | Field Instruments [318 pcs]; Install field instruments [1749 h] | 69,960 |  | 1749,00 | 2011-06-10 | 2012-04-10 | E-17-04-04 | XJ301301 | 1749 | 0 | 934 |  | 13 | 200 | 200 | C | LND | X | J | XJ30 | 1301 | J | 13 | X | IN | LND | 1301 | URMA | UDF_G3 |  |  |  |  | to be installed later |  |  |  |  |  | 2012-07-05 | 2011-09-10 |  |  |  |
| XJ421301 |  | CA13 ReactorStruc - Install Secondady Cable Trays (Start with Pipe Rack 1301) |  | 50d | 2011-12-29 | 2012-03-03 | XE401301 FF, EJ46130110 (other project), XJ321301 FS-30d, XR401301 SS+75d, AG-22201, CY-22202, E-22203, E-22206, HO-22201, HO-22202, HO-22203, HO-22204, HO-22205, HO-22206, HO-22208, HO-22209, MI-22202, PK-22211, R-22201, V-22201, V-22221, V-22222, V-22223, AG-22201-MI01 |  |  | -68d | 50d |  | Secondary cable trays [620 m]; Install secondary cable trays [2325 h] | 93,000 |  | 2325,00 | 2011-05-20 | 2011-07-20 | E-15-01-08 | XJ421301 | 2325 | 0 | 934 |  | 13 | 200 | 200 | C | LND | X | J | XJ42 | 1301 | J | 13 | X | IN | LND | 1301 | URMA |  |  |  |  |  | to be installed later |  | m | 1070 | 2011-07-27 | 2011-10-15 | 2011-11-10 | 2011-07-11 | x |  |  |
| XJ441301 |  | CA13 ReactorStruc - Install Conduits to Instrm |  | 80d | 2012-04-04 | 2012-07-09 | XJ321301 FS-30d, AG-22201, CY-22202, E-22203, E-22206, HO-22201, HO-22202, HO-22203, HO-22204, HO-22205, HO-22206, HO-22208, HO-22209, MI-22202, PK-22211, R-22201, V-22201, V-22221, V-22222, V-22223, AG-22201-MI01, XR401301, XE401301, XJ421301 FS-25d |  |  | -72d | 0d | TB26 - V - Construct-Winter partly * |  |  |  |  | 2011-06-10 | 2012-04-10 | E-17-04-04 | XJ441301 | 0 | 0 | 934 |  | 13 | 200 | 200 | C | LND | X | J | XJ44 | 1301 | J | 13 | X | IN | LND | 1301 | URMA |  |  |  |  |  | to be installed later |  |  |  |  |  | 2012-07-05 | 2011-09-10 |  |  |  |
| XJ391301 |  | CA13 ReactorStruc - Install Earthing Field Eqpt |  | 40d | 2012-05-11 | 2012-06-27 | XJ301301 FF+10d, XJ421301, XJ441301 FS-50d |  |  | -47d | 40d | TB26 - V - Construct-Winter partly * |  |  |  |  | 2011-06-10 | 2012-04-10 | E-17-04-04 | XJ391301 | 0 | 0 | 934 |  | 13 | 200 | 200 | C | LND | X | J | XJ39 | 1301 | J | 13 | X | IN | LND | 1301 | URMA |  |  |  |  |  |  |  |  |  |  |  | 2012-07-05 | 2011-09-10 |  |  |  |
| XJ541301 |  | CA13 ReactorStruc - Pulling Singlecore Cables |  | 70d | 2012-05-23 | 2012-08-13 | XJ421301 FS-25d, XJ441301 FS-40d, EJ801301 (other project), XE500C01, X3J130 FF, XJ301301 FS-40d |  |  | -72d | 15d | TB26 - V - Construct-Winter partly * | Singlecore cables [28800 m]; Pull singlecore cables [21600 h] | 864,000 |  | 21600,00 | 2011-06-10 | 2012-04-10 | E-17-04-04 | XJ541301 | 21600 | 0 | 934 |  | 13 | 200 | 200 | C | LND | X | J | XJ54 | 1301 | J | 13 | X | IN | LND | 1301 | URMA |  |  |  |  |  |  |  | m | 27608 | 2011-11-22 | 2012-03-13 | 2012-07-05 | 2011-09-10 |  |  |  |
| XJ521301 |  | CA13 ReactorStruc - Pulling Multicore Cables |  | 60d | 2012-06-07 | 2012-08-17 | XE500C01, XJ525103 SS+12d, XJ321301 SS+20d, XE401301, XJ525102 SS+15d, XJ525104 SS+10d, XJ525401 SS+18d |  |  | -30.5d | 0d | TB26 - V - Construct-Winter partly * | Multicore cables [13100 m]; Pull multicore cables [6550 h] | 262,000 |  | 6550,00 | 2011-05-20 | 2012-03-10 | E-17-01-01 | XJ521301 | 6550 | 0 | 934 |  | 13 | 200 | 200 | C | LND | X | J | XJ52 | 1301 | J | 13 | X | IN | LND | 1301 | URMA |  |  |  |  |  | to be checked |  | m | 9500 | 2011-09-29 | 2011-12-08 | 2012-06-16 | 2011-11-01 |  |  |  |
| XJ701301 |  | CA13 ReactorStruc - Instrument Tubing |  | 50d | 2012-06-16 | 2012-08-13 | XJ301301 FS+30d, XR401301 |  |  | -87d | 0d | TB26 - V - Construct-Winter partly * |  |  |  |  | 2011-06-10 | 2012-04-10 | E-17-04-04 | XJ701301 | 0 | 0 | 934 |  | 13 | 200 | 200 | C | LND | X | J | XJ70 | 1301 | J | 13 | X | IN | LND | 1301 | URMA |  |  |  |  |  |  |  |  |  |  |  | 2012-07-05 | 2011-09-10 |  |  |  |
| XJ621301 |  | CA13 ReactorStruc - Termin Multicore Cables |  | 60d | 2012-07-02 | 2012-09-10 | XJ521301 FF+20d, XJ321301 |  |  | 172d |  | TB26 - V - Construct-Winter partly * | Termination Field [2117 mhr]; Termination field [2117 h] | 211,700 |  | 2117,00 | 2011-05-20 | 2012-03-10 | E-17-01-01 | XJ621301 | 2117 | 0 | 934 |  | 13 | 200 | 200 | C | LND | X | J | XJ62 | 1301 | J | 13 | X | IN | LND | 1301 | URMA |  |  |  |  |  |  |  |  |  |  |  | 2012-06-16 | 2011-11-01 |  |  |  |
| XJ641301 |  | CA13 ReactorStruc - Termin Singlecore Cables |  | 70d | 2012-07-21 | 2012-10-10 | XJ541301 FS-35d, XJ301301 FS-40d, XJ321301, XJ391301 FS-20d, XJ701301 FS-20d |  |  | -87d | 0d | TB26 - V - Construct-Winter partly * | Termination Field [2117 mhr]; Termination field [2117 h] | 211,700 |  | 2117,00 | 2011-06-10 | 2012-04-10 | E-17-04-04 | XJ641301 | 2117 | 0 | 934 |  | 13 | 200 | 200 | C | LND | X | J | XJ64 | 1301 | J | 13 | X | IN | LND | 1301 | URMA |  |  |  |  |  |  |  |  |  |  |  | 2012-07-05 | 2011-09-10 |  |  |  |
| XJ801301 |  | CA13 ReactorStruc - Inspections/ Mech. Acceptance/ Loop Checks |  | 80d | 2012-09-12 | 2012-12-15 | XJ391301 FS-30d, XJ701301 SS, XE601301, EJ801301 (other project), X0300015, XJ641301 FF+30d, X030410030, X3J120, XJ621330 FF+30d |  |  | -95.5d | 0d |  | Loop Checks [510 pcs]; Loop checks [2550 h] | 102,000 |  | 2550,00 | 2011-06-10 | 2012-04-30 | E-17-02-01 | XJ801301 | 2550 | 0 | 934 |  | 13 | 200 | 200 | C | LND | X | J | XJ80 | 1301 | J | 13 | X | LT | LND | 1301 | URMA |  |  |  |  |  |  |  |  |  |  |  | 2012-08-18 | 2012-03-01 |  |  | 2012-08-18 |

Notes:
- XR201301: Current Status: Ueberpruefen PRED Materiallieferung (WL)
- XR401301: Current Status: 110803 (WL): Delete Pred. V-22224 INSTRUMENT AIR VESSEL
- XE801301: Current Status: 110803 (WL): Delete PRED V-22224 INSTRUMENT AIR VESSEL
- XJ321301: Current Status: 110803 (WL): Delete Pred. V-22224 INSTRUMENT AIR VESSEL

| ID | WBS | Activity | Type | Duration | Start | Finish | Predecessors | Complete | Remaining | Total float | Free float | Constraint | Calendar | Resources | Cost | Actual cost | TB26 Ressource Budget | UDF_SAVE ACT ID | UDF_BUDGETED LABOR UNIT | UDF_ACTUAL LABOR UNIT | Department | Constr. Area | PMT-Area | PMT-Schedule Org | PMT-Phase | PMT-Respons. | WBS Phase | WBS Discipline | WBS Type of Work | WBS Objects | Russia WBS Discipline (Russia) | Russia Construction Area | Russia WBS Phase | IMS | UPT | Russia WBS Objects | Subcontractor | UDF_CONTRACT FINISH DATE | UDF_CONTRACT ITEM | UDF_CHECK BASELINE | Type of Work | Zeigen/n. Zeigen | TB26 Semantics | Inquiry/Order No | UDF_CONTRACT INDICATOR | UDF_PLANNED START | UDF_SELECT UPDATE PROGRESS | UDF_CHECK RESOURCE DATES | UDF_CONTRACT START DATE | UDF_PLANNED FINISH | Civil item | 4 week lookahead |
| --- | --- | --- | --- | --- | --- | --- | --- | --- | --- | --- | --- | --- | --- | --- | --- | --- | --- | --- | --- | --- | --- | --- | --- | --- | --- | --- | --- | --- | --- | --- | --- | --- | --- | --- | --- | --- | --- | --- | --- | --- | --- | --- | --- | --- | --- | --- | --- | --- | --- | --- | --- | --- |
|  | S | **Safety & Environment** |  |  |  |  |  |  |  |  |  |  |  |  |  |  |  |  |  |  |  |  |  |  |  |  |  |  |  |  |  |  |  |  |  |  |  |  |  |  |  |  |  |  |  |  |  |  |  |  |  |  |
|  | W | **Painting** |  |  | 2012-04-16 | 2012-05-22 |  |  |  |  |  |  |  |  |  |  |  |  |  |  |  |  |  |  |  |  |  |  |  |  |  |  |  |  |  |  |  |  |  |  |  |  |  |  |  |  |  |  |  |  |  |  |
| XW501301 |  | CA13 ReactorStruc - Surf.Protection Piping |  | 30d | 2012-04-16 | 2012-05-22 | XR201301 SS+20d, XN801301 SS+20d, XR801301 FF+10d |  |  | -49d | 0d |  |  | Piping painting [2223 sqm]; Piping painting [5557 h] | 2,920.88 |  | 5557,00 | XW501301 | 5557 | 0 | 934 | 13 | 200 | 200 | C | LND | X | W | XW50 | 1301 | W | 13 | X | PA | LND | 1301 | VNZM |  |  |  |  |  |  |  |  |  |  |  |  |  |  |  |
|  | V | **Insulation** |  |  | 2012-05-29 | 2012-10-16 |  |  |  |  |  |  |  |  |  |  |  |  |  |  |  |  |  |  |  |  |  |  |  |  |  |  |  |  |  |  |  |  |  |  |  |  |  |  |  |  |  |  |  |  |  |  |
| XV301301 |  | CA13 ReactorStruc - Insulation Equipment |  | 100d | 2012-05-29 | 2012-09-22 | XE801301 SS+20d |  |  | -45d | 0d |  | TB26 - V - Construct-Winter partly * | Equipment insulation [750 sqm]; Equipment insulation [9375 h] | 2,079.79 |  | 9375,00 | XV301301 | 9375 | 0 | 934 | 13 | 200 | 200 | C | LND | X | V | XV30 | 1301 | V | 13 | X | INS | LND | 1301 | VNZM | 2012-03-30 | E-13-03 |  |  |  |  |  |  |  |  |  |  |  |  |  |
| XV501301 |  | CA13 ReactorStruc - Insulation Piping |  | 100d | 2012-06-22 | 2012-10-16 | XV301301 FF+20d, XR601301 SS+20d, XE801301 FF+20d |  |  | -45d | 50.5d |  | TB26 - V - Construct-Winter partly * | Piping insulation [1900 sqm]; Piping insulation [14250 h] | 8,325.09 |  | 14250,00 | XV501301 | 14250 | 0 | 934 | 13 | 200 | 200 | C | LND | X | V | XV50 | 1301 | V | 13 | X | INS | LND | 1301 | VNZM | 2012-04-30 | E-13-01 |  |  |  |  |  |  |  |  |  |  |  |  |  |
|  | 02 | **CA13 - Teal Bldg Steel Structure** |  |  |  |  |  |  |  |  |  |  |  |  |  |  |  |  |  |  |  |  |  |  |  |  |  |  |  |  |  |  |  |  |  |  |  |  |  |  |  |  |  |  |  |  |  |  |  |  |  |  |
|  | 03 | **CA13 - Connection Structure to Extruder Bldg.** |  |  | 2011-03-07 | 2012-02-25 |  |  |  |  |  |  |  |  |  |  |  |  |  |  |  |  |  |  |  |  |  |  |  |  |  |  |  |  |  |  |  |  |  |  |  |  |  |  |  |  |  |  |  |  |  |  |
|  | C | **Civil Work** |  |  |  |  |  |  |  |  |  |  |  |  |  |  |  |  |  |  |  |  |  |  |  |  |  |  |  |  |  |  |  |  |  |  |  |  |  |  |  |  |  |  |  |  |  |  |  |  |  |  |
|  | N | **Structural Steel** |  |  | 2011-03-07 | 2012-02-01 |  |  |  |  |  |  |  |  |  |  |  |  |  |  |  |  |  |  |  |  |  |  |  |  |  |  |  |  |  |  |  |  |  |  |  |  |  |  |  |  |  |  |  |  |  |  |
| XN701303 |  | CA13 SB1303 - KMD Assy Drawings | milestone | 0d | 2011-03-07 A | 2011-03-07 A |  | 100% |  |  |  | finish on 2011-03-07 | TB26 - V - Construct-Winter partly * |  |  |  | 22t | XN701303 | 0 | 0 | 934 | 13 | 200 | 200 | C | LND | X | N | XN05 | 1303 | N | 13 | X | SS | LND | 1303 |  |  |  | x | XNK | KMD |  |  |  |  |  |  |  |  |  |  |
| XN711303 |  | CA13 SB1303 - Steel Deliveries | milestone | 0d | 2011-04-12 A | 2011-04-12 A |  | 100% |  |  |  | finish on or after 2011-04-11 | TB26 - 3 - Construction Normal 7days * CA17 |  |  |  | 22t | XN711303 | 0 | 0 | 934 | 13 | 200 | 200 | C | LND | X | N | XN06 | 1303 | N | 13 | X | SS | LND | 1303 |  |  |  |  | XNK | SD |  |  |  |  |  |  |  |  |  |  |
| XN201303 |  | CA13 SB1303 - Installation Steel Structure |  | 25d | 2011-12-16 | 2012-01-20 | XN701303, XN201730, XN401301 SS, XN711303 FS+10d, P3N012D (other project) FS+10d, P3N02IN (other project) |  |  | -98d | 0d |  |  | Piperacks, Main Structures [55 t]; Piperacks, Main structures [2337.5 h] | 1,625.99 |  | 2337,50 | XN201303 | 2337,5 | 0 | 934 | 13 | 200 | 200 | C | LND | X | N | XN20 | 1303 | N | 13 | X | SS | LND | 1303 | ChSK |  |  |  | PU10 |  | t | 2DC8990 |  |  |  |  |  |  |  |  |
| XN601303 |  | CA13 SB1303 - Install Gratings |  | 20d | 2012-01-10 | 2012-02-01 | XN401303 FF |  |  | -98d | 0d |  |  | Grating [250 sqm]; Grating [937.5 h] | 12,934.04 |  | 937,50 | XN601303 | 937,5 | 0 | 934 | 13 | 200 | 200 | C | LND | X | N | XN60 | 1303 | N | 13 | X | SS | LND | 1303 | ChSK |  |  |  | XNK |  |  |  |  |  |  |  |  |  |  |  |
| XN401303 |  | CA13 SB1303 - Install Railings,Ladders,etc. |  | 15d | 2012-01-16 | 2012-02-01 | XN201303 FF+10d |  |  | -98d | 0d |  |  | Ladders & platforms [4 t]; Ladders & platforms [400 h] | 155.21 |  | 400,00 | XN401303 | 400 | 0 | 934 | 13 | 200 | 200 | C | LND | X | N | XN40 | 1303 | N | 13 | X | SS | LND | 1303 | ChSK |  |  |  | XNK |  |  |  |  |  |  |  |  |  |  |  |
|  | H | **HVAC** |  |  |  |  |  |  |  |  |  |  |  |  |  |  |  |  |  |  |  |  |  |  |  |  |  |  |  |  |  |  |  |  |  |  |  |  |  |  |  |  |  |  |  |  |  |  |  |  |  |  |
|  | U | **Package Units** |  |  |  |  |  |  |  |  |  |  |  |  |  |  |  |  |  |  |  |  |  |  |  |  |  |  |  |  |  |  |  |  |  |  |  |  |  |  |  |  |  |  |  |  |  |  |  |  |  |  |
|  | B | **Mechanical - Stationary Equipment** |  |  |  |  |  |  |  |  |  |  |  |  |  |  |  |  |  |  |  |  |  |  |  |  |  |  |  |  |  |  |  |  |  |  |  |  |  |  |  |  |  |  |  |  |  |  |  |  |  |  |
|  | M | **Mechanical - Rotating Equipment** |  |  |  |  |  |  |  |  |  |  |  |  |  |  |  |  |  |  |  |  |  |  |  |  |  |  |  |  |  |  |  |  |  |  |  |  |  |  |  |  |  |  |  |  |  |  |  |  |  |  |
|  | R | **Piping** |  |  | 2011-07-29 | 2012-02-25 |  |  |  |  |  |  |  |  |  |  |  |  |  |  |  |  |  |  |  |  |  |  |  |  |  |  |  |  |  |  |  |  |  |  |  |  |  |  |  |  |  |  |  |  |  |  |
| XR201303 |  | CA13 SB1303 - Piping Prefabrication |  | 107d | 2011-07-29 A | 2011-12-01 | ER491304 (other project) |  | 82d | -56d | 42d |  |  | A/G piping prefabrication [120 Fpi]; A/G Piping (Prefab) [450 h] |  |  | 450,00 | XR201303 | 450 | 0 | 934 | 13 | 200 | 200 | C | LND | X | R | XR20 | 1303 | R | 13 | X | PRP | LND | 1303 | VNZM |  |  |  |  |  |  |  | UDF_G4 | 2011-03-30 | 27.8. | x |  |  |  |  |
| XR401303 |  | CA13 SB1303 - Piping Installation |  | 25d | 2012-01-27 | 2012-02-25 | XN601303 FF+20d, XR201303 |  |  | -98d | 1d |  |  | A/G piping field installation [110 Fpi]; A/G Piping (Field) [687.5 h] |  |  | 687,50 | XR401303 | 687,5 | 0 | 934 | 13 | 200 | 200 | C | LND | X | R | XR40 | 1303 | R | 13 | X | PI | LND | 1303 | VNZM | 2011-11-30 | E-06-03-04 |  |  |  |  |  |  |  |  |  | 2011-01-20 | 2012-02-11 |  |  |
|  | E | **Electrical** |  |  |  |  |  |  |  |  |  |  |  |  |  |  |  |  |  |  |  |  |  |  |  |  |  |  |  |  |  |  |  |  |  |  |  |  |  |  |  |  |  |  |  |  |  |  |  |  |  |  |
|  | J | **Instrumentation** |  |  |  |  |  |  |  |  |  |  |  |  |  |  |  |  |  |  |  |  |  |  |  |  |  |  |  |  |  |  |  |  |  |  |  |  |  |  |  |  |  |  |  |  |  |  |  |  |  |  |
|  | S | **Safety & Environment** |  |  |  |  |  |  |  |  |  |  |  |  |  |  |  |  |  |  |  |  |  |  |  |  |  |  |  |  |  |  |  |  |  |  |  |  |  |  |  |  |  |  |  |  |  |  |  |  |  |  |
|  | W | **Painting** |  |  |  |  |  |  |  |  |  |  |  |  |  |  |  |  |  |  |  |  |  |  |  |  |  |  |  |  |  |  |  |  |  |  |  |  |  |  |  |  |  |  |  |  |  |  |  |  |  |  |
|  | V | **Insulation** |  |  |  |  |  |  |  |  |  |  |  |  |  |  |  |  |  |  |  |  |  |  |  |  |  |  |  |  |  |  |  |  |  |  |  |  |  |  |  |  |  |  |  |  |  |  |  |  |  |  |
|  | 04 | **CA13 - Connection Structure Reactor to Teal Bldg** |  |  | 2010-08-24 | 2012-08-27 |  |  |  |  |  |  |  |  |  |  |  |  |  |  |  |  |  |  |  |  |  |  |  |  |  |  |  |  |  |  |  |  |  |  |  |  |  |  |  |  |  |  |  |  |  |  |
|  | C | **Civil Work** |  |  | 2010-08-24 | 2011-02-21 |  |  |  |  |  |  |  |  |  |  |  |  |  |  |  |  |  |  |  |  |  |  |  |  |  |  |  |  |  |  |  |  |  |  |  |  |  |  |  |  |  |  |  |  |  |  |
| XC20130410 |  | CA13 TealStr SK1304 -Concrete Works Foundation |  | 32d | 2010-08-24 A | 2010-09-29 A | XC201300 FS+35d, EC28130410 (other project) FS+5d, EC45130415 (other project) FS+20d, XC151300, IMS-C-000060 FF, EC45130405 (other project) | 100% |  |  |  |  | TB26 - V - Construct-Winter partly * | Concrete works [170 cbm]; Concrete works [5100 h] | 2,771.58 |  | 5100,00 | XC20130410 | 5100 | 5100 | 934 | 13 | 200 | 200 | C | MO03 | X | C | XC20 | 1304 | C | 13 | X | mis | LND | 1304 | MO11 |  |  |  |  |  |  |  |  |  |  |  |  |  |  |  |
| XC20130405 |  | CA13 TealStr SK1304 - Precast Concrete Elements |  | 54d | 2010-11-22 A | 2011-01-31 A | EC45130415 (other project), P3C02D2 (other project), EC28130406 (other project) FS+5d | 100% |  |  |  |  |  |  |  |  |  | XC20130405 | 0 | 0 | 934 | 13 | 200 | 200 | C | MO04 | X | C | XC20 | 1304 | C | 13 | X | pre | LND | 1304 | MO11 |  |  |  |  |  |  |  |  |  |  |  |  |  |  |  |
| XC20130415 |  | CA13 TealStr SK1304 - Erection Precast Elements |  | 18d | 2011-02-01 A | 2011-02-21 A | XC20130410 FS-10d, XC20130405 | 100% |  |  |  |  |  | Precast Concrete Works [70 cbm]; Precast concrete works [175 h] | 7,000 | 7,000 | 175,00 | XC20130415 | 175 | 175 | 934 | 13 | 200 | 200 | C | MO04 | X | C | XC20 | 1304 | C | 13 | X | OB | LND | 1304 | MO11 |  |  |  |  |  |  |  |  |  |  |  |  |  | Comp | x |

Notes:
- XW501301: P3 Activity Log Info: Clarification Surface / Protection during Prefab
- XN711303: Scope: 09.02.2011: weight: 50 ton - Apr 50 ton
- XC20130415: Current Status: 05.02.2011 (O.Siegel): keine Mengenmeldung im CPM-Report. Laut MO11 / (04.02.2011) der Endtermin: 21-Feb-11 wird gehalten / 13.01.2011 (Oxana): zum 01.01.2011 wurden keine Arbeiten durchgefьhrt / (Angaben aus CPMR). Startdatum auf den 17.01.2011 verschoben und die Dauer / von 20 auf 15 Tage verkьrzt. Endtermin wird gehalten (Angaben von / Mostostroy).

| ID | WBS | Activity | Type | Duration | Start | Finish | Predecessors | Complete | Remaining | Planned start | Planned finish | Total float | Free float | Constraint | Calendar | Resources | Cost | Actual cost | TB26 Ressource Budget | UDF_SAVE ACT ID | UDF_CHECK BASELINE | UDF_BUDGETED LABOR UNIT | UDF_ACTUAL LABOR UNIT | Department | Type of Work | Constr. Area | PMT-Area | PMT-Schedule Org | PMT-Phase | PMT-Respons. | Zeigen/n. Zeigen | WBS Phase | WBS Discipline | WBS Type of Work | WBS Objects | Russia WBS Discipline (Russia) | Russia Construction Area | Russia WBS Phase | IMS | UPT | Russia WBS Objects | UDF_CONTRACT START DATE | UDF_CONTRACT FINISH DATE | UDF_CONTRACT ITEM | UDF_CONTRACT INDICATOR | TB26 Semantics | 4 week lookahead | Subcontractor | Comments | UDF_SELECT UPDATE PROGRESS | UDF_CHECK RESOURCE DATES | UDF_PLANNED START | UDF_PLANNED FINISH | TB26 Material Res Values | UDF_ELECTRICAL START | UDF_ELECTRICAL FINISH | UDF_CONTRACT FINISH DATE REV1 | UDF_CONTRACT START DATE REV1 | UDF_Vendor Representatives | UDF_ELECTRICAL SEQUENCE | UDF_PREDECESSOR |
| --- | --- | --- | --- | --- | --- | --- | --- | --- | --- | --- | --- | --- | --- | --- | --- | --- | --- | --- | --- | --- | --- | --- | --- | --- | --- | --- | --- | --- | --- | --- | --- | --- | --- | --- | --- | --- | --- | --- | --- | --- | --- | --- | --- | --- | --- | --- | --- | --- | --- | --- | --- | --- | --- | --- | --- | --- | --- | --- | --- | --- | --- |
|  | N | **Structural Steel** |  |  | 2011-03-10 | 2011-09-28 |  |  |  |  |  |  |  |  |  |  |  |  |  |  |  |  |  |  |  |  |  |  |  |  |  |  |  |  |  |  |  |  |  |  |  |  |  |  |  |  |  |  |  |  |  |  |  |  |  |  |  |  |  |  |  |
| XN701304 |  | CA13 TealStr SK1304 - KMD Assy Drawings | milestone | 0d | 2011-03-10 A | 2011-03-10 A |  | 100% |  |  |  |  |  | finish on 2011-03-10 | TB26 - V - Construct-Winter partly * |  |  |  | 22t | XN701304 | x | 0 | 0 | 934 | XNK | 13 | 200 | 200 | C | LND | KMD | X | N | XN05 | 1304 | N | 13 | X | SS | LND | 1304 |  |  |  |  |  |  |  |  |  |  |  |  |  |  |  |  |  |  |  |  |
| XN711304 |  | CA13 TealStr SK1304 - Steel Deliveries | milestone | 0d | 2011-03-27 A | 2011-03-27 A |  | 100% |  |  |  |  |  | finish on or after 2011-03-18 | TB26 - 3 - Construction Normal 7days * CA17 |  |  |  | 22t | XN711304 |  | 0 | 0 | 934 | XNK | 13 | 200 | 200 | C | LND | SD | X | N | XN06 | 1304 | N | 13 | X | SS | LND | 1304 |  |  |  |  |  |  |  |  |  |  |  |  |  |  |  |  |  |  |  |  |
| XN201304 |  | CA13 TealStr SK1304 - Erection Primary Steel |  | 20d | 2011-09-06 | 2011-09-28 | XN701304, XN711304 FS+10d, XC20130415 SS+17d, P3N02HN (other project), XC401322, P3N012D (other project) FS+10d, P3N012D (other project) FF+10d, XN201301u SS+60d |  |  |  |  | 54d | 0d |  | TB26 - V - Construct-Winter partly * | Piperacks, Main Structures [59 t]; Piperacks, Main structures [2507.5 h] | 1,773.81 |  | 2507,50 | XN201304 |  | 2507,5 | 0 | 934 | XNK | 13 | 200 | 200 | C | LND |  | X | N | XN20 | 1304 | N | 13 | X | SS | LND | 1304 | 2011-02-10 | 2011-03-05 | E-04-06 | UDF_G4 | t | x | ChSK |  |  |  |  |  |  |  |  |  |  |  |  |  |
| XN401304 |  | CA13 TealStr SK1304 - Install Railings,Ladders |  | 10d | 2011-09-17 | 2011-09-28 | XN201304 FS-10d |  |  |  |  | 54d | 0d | start on or after 2011-06-13 | TB26 - V - Construct-Winter partly * | Ladders & platforms |  |  | 300,00 | XN401304 | x | 300 | 0 | 934 | XNK | 13 | 200 | 200 | C | LND |  | X | N | XN40 | 1304 | N | 13 | X | SS | LND | 1304 |  |  |  |  |  |  | ChSK | no ladders |  |  |  |  |  |  |  |  |  |  |  |  |
| XN601304 |  | CA13 TealStr SK1304 - Install Gratings |  | 10d | 2011-09-17 | 2011-09-28 | PN691304 (other project), XN401304 SS |  |  |  |  | 54d | 0d | start on or after 2011-06-13 | TB26 - V - Construct-Winter partly * | Grating [110 sqm]; Grating [412.5 h] | 3,621.53 |  | 412,50 | XN601304 |  | 412,5 | 0 | 934 | XNK | 13 | 200 | 200 | C | LND |  | X | N | XN60 | 1304 | N | 13 | X | SS | LND | 1304 |  |  |  |  |  |  | ChSK | no gratings |  |  |  |  |  |  |  |  |  |  |  |  |
|  | H | **HVAC** |  |  |  |  |  |  |  |  |  |  |  |  |  |  |  |  |  |  |  |  |  |  |  |  |  |  |  |  |  |  |  |  |  |  |  |  |  |  |  |  |  |  |  |  |  |  |  |  |  |  |  |  |  |  |  |  |  |  |  |
|  | U | **Package Units** |  |  |  |  |  |  |  |  |  |  |  |  |  |  |  |  |  |  |  |  |  |  |  |  |  |  |  |  |  |  |  |  |  |  |  |  |  |  |  |  |  |  |  |  |  |  |  |  |  |  |  |  |  |  |  |  |  |  |  |
|  | B | **Mechanical - Stationary Equipment** |  |  |  |  |  |  |  |  |  |  |  |  |  |  |  |  |  |  |  |  |  |  |  |  |  |  |  |  |  |  |  |  |  |  |  |  |  |  |  |  |  |  |  |  |  |  |  |  |  |  |  |  |  |  |  |  |  |  |  |
|  | M | **Mechanical - Rotating Equipment** |  |  |  |  |  |  |  |  |  |  |  |  |  |  |  |  |  |  |  |  |  |  |  |  |  |  |  |  |  |  |  |  |  |  |  |  |  |  |  |  |  |  |  |  |  |  |  |  |  |  |  |  |  |  |  |  |  |  |  |
|  | R | **Piping** |  |  | 2011-08-22 | 2012-04-02 |  |  |  |  |  |  |  |  |  |  |  |  |  |  |  |  |  |  |  |  |  |  |  |  |  |  |  |  |  |  |  |  |  |  |  |  |  |  |  |  |  |  |  |  |  |  |  |  |  |  |  |  |  |  |  |
| XR201304 |  | CA13 TealStr SK1304 - Piping Prefabrication |  | 85d | 2011-08-22 A | 2011-12-03 | ER491304 (other project) FS+20d |  | 84d | 2011-08-26 | 2011-12-03 | 105d | 400.5d |  |  | A/G piping prefabrication [3650 Fpi]; A/G Piping (Prefab) [13687.5 h] | 12,771.44 |  | 13687,50 | XR201304 |  | 13687,5 | 0 | 934 |  | 13 | 200 | 200 | C | LND |  | X | R | XR20 | 1304 | R | 13 | X | PRP | LND | 1304 |  |  |  | UDF_G4 |  | x | VNZM |  | 27.8. | x |  |  |  |  |  |  |  |  |  |  |
| XR401304 |  | CA13 TealStr SK1304 - Piping Installation |  | 60d | 2011-10-11 | 2011-12-20 | XN201304 SS+12d, XN601304 SS+20d, P3J04CS1 (other project), P3J02AS (other project) FF+20d, P3J02DS (other project) FF+20d, P3S01S (other project) FF+20d, IMS-C-000190 FF, XR201304 SS+20d |  |  |  |  | 82d | 0d |  |  | A/G piping field installation [4450 Fpi]; A/G Piping (Field) [27812.5 h] | 45,409.57 |  | 27812,50 | XR401304 |  | 27812,5 | 0 | 934 |  | 13 | 200 | 200 | C | LND |  | X | R | XR40 | 1304 | R | 13 | X | PI | LND | 1304 | 2011-01-20 |  | E-06-03-04 |  |  |  | VNZM |  |  |  | 2011-03-30 |  |  |  |  |  |  |  |  |  |
| XR601304 |  | CA13 TealStr SK1304 - Piping Pressure Tests |  | 40d | 2012-02-02 | 2012-03-21 | X0300020, XR605103 FF+20d, XR401304 FF+12d |  |  |  |  | 54d | 0d |  |  |  |  |  | 1013 | XR601304 |  | 0 | 0 | 934 |  | 13 | 200 | 200 | C | LND |  | X | R | XR60 | 1304 | R | 13 | X | HY | LND | 1304 |  |  | E-06-03-04 |  |  |  | VNZM |  |  |  |  |  |  |  |  |  |  |  |  |  |
| XR801304 |  | CA13 TealStr SK1304 - Piping Reinstatement |  | 30d | 2012-02-27 | 2012-04-02 | XR601304 FF+10d, IMS-C-000360 FF |  |  |  |  | 305.5d |  |  |  |  |  |  | 507 | XR801304 |  | 0 | 0 | 934 |  | 13 | 200 | 200 | C | LND |  | X | R | XR80 | 1304 | R | 13 | X | PI | LND | 1304 |  | 2011-11-30 | E-06-03-04 |  |  |  | VNZM |  |  |  |  | 2012-02-11 |  |  |  |  |  |  |  |  |
|  | E | **Electrical** |  |  | 2010-08-24 | 2012-08-27 |  |  |  |  |  |  |  |  |  |  |  |  |  |  |  |  |  |  |  |  |  |  |  |  |  |  |  |  |  |  |  |  |  |  |  |  |  |  |  |  |  |  |  |  |  |  |  |  |  |  |  |  |  |  |  |
| XC911304 |  | CA13 TealStr SK1304-Install Earthing&LightnSys_CIVIL |  | 42d | 2010-08-24 A | 2010-10-11 A | EE901304 (other project), XC20130410 FF+10d | 100% |  |  |  |  |  |  |  | Grounding & Lightning [100 pcs]; Grounding & Lightning [1125 h] | 45,000 | 45,000 | 1125,00 | XC911304 |  | 1125 | 1125 | 934 |  | 13 | 200 | 200 | C | LND |  | X | C | XE91 | 1304 | C | 13 | X | EA | LND | 1304 | 2011-05-10 | 2011-11-30 | E-16-07-05 |  |  |  | MO11 |  |  |  |  |  |  |  |  |  |  |  |  |  |
| XE401304 |  | CA13 TealStr SK1304 - Install Cable Trays |  | 25d | 2011-11-16 | 2011-12-14 | EE46510120 (other project) FF, EE46130410 (other project), XN201304, XR401304 SS+30d |  |  |  |  | 82d | 5d |  |  | Cable trays/conduits [310 m]; Cable trays [930 h] | 37,200 |  | 930,00 | XE401304 | x | 930 | 0 | 934 |  | 13 | 200 | 200 | C | LND |  | X | E | XE40 | 1304 | E | 13 | X | EL | LND | 1304 | 2011-05-10 | 2011-08-20 | E-15-01-09 |  | m |  | URMA |  |  |  |  |  | 510 | 2011-06-16 | 2011-08-12 | 2011-12-20 | 2011-07-20 |  |  |  |
| XE911305 |  | CA13 TealStr SK1304-Install Earthing&LightnSys_E/I |  | 25d | 2011-12-21 | 2012-01-25 | XJ421304, XN201304 SS, XE401304 |  |  |  |  | 130d | 217d |  |  |  |  |  | 115 | XE911305 |  | 0 | 0 | 934 |  | 13 | 200 | 200 | C | LND |  | X | E | XE91 | 1304 | E | 13 | X | EA | LND | 1304 | 2011-05-10 | 2011-11-30 | E-16-07-05 |  |  |  | URMA |  |  |  |  |  |  |  |  | 2012-04-15 | 2011-07-25 |  |  |  |
| XE801304 |  | CA13 TealStr SK1304 - Install Heat Tracing |  | 80d | 2012-01-21 | 2012-04-25 | XW501304 FF+20d, E3E1950 (other project), XE800C00 SS, P3E19S (other project), XR401304 SS+20d, XR601304 FF+30d |  |  |  |  | 54d | 0d |  |  | Electrical Heat Tracing [1100 m]; Electrical heat tracing [550 h] | 22,000 |  | 550,00 | XE801304 |  | 550 | 0 | 934 |  | 13 | 200 | 200 | C | LND |  | X | E | XE80 | 1304 | E | 13 | X | HT | LND | 1304 | 2011-06-20 | 2012-03-20 | E-16-04-01 |  |  |  | URMA |  |  |  |  |  |  |  |  | 2012-06-30 | 2011-09-15 | 005 |  |  |
| XE501304 |  | CA13 TealStr SK1304-Cable Pulling Electric |  | 60d | 2012-06-18 | 2012-08-27 | XE500C01, XE505104 SS+10d, EE561304 (other project), XE505103 SS+10d, XE401304 SS+18d, XE505401 SS+12d, XE501301 SS |  |  |  |  | -71.5d | 0d |  | TB26 - V - Construct-Winter partly * | Cable Pulling [5300 m]; Cable pulling [2650 h] | 106,000 |  | 2650,00 | XE501304 |  | 2650 | 0 | 934 |  | 13 | 200 | 200 | C | LND |  | X | E | XE50 | 1304 | E | 13 | X | EL | LND | 1304 | 2011-05-20 | 2012-02-10 | E-16-01-01 | UDF_G3 | m |  | URMA |  |  |  |  |  | 5500 | 2011-08-27 | 2011-11-07 | 2012-07-01 | 2011-10-01 |  | XJ321321 | XE401304-SS+18, XE505103-SS+12, XE505104-SS+6 |
|  | J | **Instrumentation** |  |  | 2011-11-16 | 2012-08-06 |  |  |  |  |  |  |  |  |  |  |  |  |  |  |  |  |  |  |  |  |  |  |  |  |  |  |  |  |  |  |  |  |  |  |  |  |  |  |  |  |  |  |  |  |  |  |  |  |  |  |  |  |  |  |  |
| XJ421304 |  | CA13 TealStr SK1304 - Install Secondary CableTrays |  | 30d | 2011-11-16 | 2011-12-20 | XR401304 SS+30d, XE401304 FF, EJ46130410 (other project) |  |  |  |  | 130d | 0d |  |  | Secondary cable trays [260 m]; Install secondary cable trays [975 h] | 39,000 |  | 975,00 | XJ421304 | x | 975 | 0 | 934 |  | 13 | 200 | 200 | C | LND |  | X | J | XJ42 | 1304 | J | 13 | X | IN | LND | 1304 | 2011-05-20 | 2011-08-20 | E-15-01-09 |  | m |  | URMA |  |  |  |  |  | 450 | 2011-06-16 | 2011-08-12 | 2011-12-20 | 2011-07-20 |  |  |  |
| XJ521304 |  | CA13 TealStr SK1304 -Pulling Instrument Cables |  | 50d | 2012-06-07 | 2012-08-06 | XE500C01, XJ525103 SS+12d, XE401304, XJ521301 SS, XJ525401 SS+18d, XJ525104 SS+10d, XJ525102 SS+18d |  |  |  |  | -30.5d | 0d |  | TB26 - V - Construct-Winter partly * | Multicore cables [4800 m]; Pull multicore cables [2400 h] | 96,000 |  | 2400,00 | XJ521304 |  | 2400 | 0 | 934 |  | 13 | 200 | 200 | C | LND |  | X | J | XJ52 | 1304 | J | 13 | X | IN | LND | 1304 | 2011-05-10 | 2012-03-20 | E-17-04-05 |  | m |  | URMA |  |  |  |  |  | 3500 | 2011-09-03 | 2011-10-31 | 2012-08-15 | 2011-07-25 |  |  |  |

Notes:
- XN711304: Scope: 09.02.2011: weight: 65 ton - Mrz 65 ton
- XE401304: Current Status: 20110705 (O.Siegel): keine / Abhдngigkeit von Piping, da die Betonfeuerschutzplaten

| ID | WBS | Activity | Type | Duration | Start | Finish | Predecessors | Complete | Remaining | Planned start | Planned finish | Total float | Free float | Constraint | Calendar | Resources | Cost | Actual cost | TB26 Ressource Budget | UDF_SELECT UPDATE PROGRESS | UDF_SAVE ACT ID | UDF_BUDGETED LABOR UNIT | UDF_ACTUAL LABOR UNIT | UDF_CHECK RESOURCE DATES | Department | Constr. Area | PMT-Area | PMT-Schedule Org | PMT-Phase | PMT-Respons. | WBS Phase | WBS Discipline | WBS Type of Work | WBS Objects | Russia WBS Discipline (Russia) | Russia Construction Area | Russia WBS Phase | IMS | UPT | Russia WBS Objects | Subcontractor | UDF_CONTRACT FINISH DATE | UDF_CONTRACT ITEM | Civil item | UDF_CHECK BASELINE | Type of Work | Zeigen/n. Zeigen | UDF_CONTRACT START DATE | TB26 Semantics | 4 week lookahead | UDF_CONTRACT FINISH DATE REV1 | UDF_CONTRACT START DATE REV1 | UDF_COMMENTS_0827 | UDF_CONTRACT INDICATOR | UDF_CHECK CRITICAL PATH | UDF_ELECTRICAL SEQUENCE | UDF_EXPECTED START | UDF_EXPECTED FINISH | UDF_Concrete | Filter | UDF_SELECT |
| --- | --- | --- | --- | --- | --- | --- | --- | --- | --- | --- | --- | --- | --- | --- | --- | --- | --- | --- | --- | --- | --- | --- | --- | --- | --- | --- | --- | --- | --- | --- | --- | --- | --- | --- | --- | --- | --- | --- | --- | --- | --- | --- | --- | --- | --- | --- | --- | --- | --- | --- | --- | --- | --- | --- | --- | --- | --- | --- | --- | --- | --- |
|  | S | **Safety & Environment** |  |  |  |  |  |  |  |  |  |  |  |  |  |  |  |  |  |  |  |  |  |  |  |  |  |  |  |  |  |  |  |  |  |  |  |  |  |  |  |  |  |  |  |  |  |  |  |  |  |  |  |  |  |  |  |  |  |  |  |
|  | W | **Painting** |  |  | 2011-09-14 | 2011-10-13 |  |  |  |  |  |  |  |  |  |  |  |  |  |  |  |  |  |  |  |  |  |  |  |  |  |  |  |  |  |  |  |  |  |  |  |  |  |  |  |  |  |  |  |  |  |  |  |  |  |  |  |  |  |  |  |
| XW501304 |  | CA13 TealStr SK1304 - Surf.Protection Piping |  | 26d | 2011-09-14 | 2011-10-13 | XR201304 SS+20d |  |  |  |  | 192d | 138d |  |  | Piping painting [1277 sqm]; Piping painting [3192 h] | 1,677.73 |  | 3192,00 | 27.8. | XW501304 | 3192 | 0 | x | 934 | 13 | 200 | 200 | C | LND | X | W | XW50 | 1304 | W | 13 | X | PA | LND | 1304 | VNZM |  |  |  |  |  |  |  |  |  |  |  |  |  |  |  |  |  |  |  |  |
|  | V | **Insulation** |  |  | 2012-03-10 | 2012-05-21 |  |  |  |  |  |  |  |  |  |  |  |  |  |  |  |  |  |  |  |  |  |  |  |  |  |  |  |  |  |  |  |  |  |  |  |  |  |  |  |  |  |  |  |  |  |  |  |  |  |  |  |  |  |  |  |
| XV501304 |  | CA13 TealStr SK1304 - Insulation Piping |  | 60d | 2012-03-10 | 2012-05-21 | XE801304 FF+20d, XE801304 SS+20d |  |  |  |  | 81d | 176.5d |  |  | Piping insulation [1100 sqm]; Piping insulation [8250 h] | 6,373.89 |  | 8250,00 |  | XV501304 | 8250 | 0 |  | 934 | 13 | 200 | 200 | C | LND | X | V | XV50 | 1304 | V | 13 | X | INS | LND | 1304 | VNZM | 2012-04-30 | E-13-01 |  |  |  |  |  |  |  |  |  |  |  |  |  |  |  |  |  |  |
|  | 05 | **CA13 - Agitator Removable Unit** |  |  | 2010-10-04 | 2012-04-06 |  |  |  |  |  |  |  |  |  |  |  |  |  |  |  |  |  |  |  |  |  |  |  |  |  |  |  |  |  |  |  |  |  |  |  |  |  |  |  |  |  |  |  |  |  |  |  |  |  |  |  |  |  |  |  |
|  | C | **Civil Work** |  |  | 2010-10-04 | 2011-12-05 |  |  |  |  |  |  |  |  |  |  |  |  |  |  |  |  |  |  |  |  |  |  |  |  |  |  |  |  |  |  |  |  |  |  |  |  |  |  |  |  |  |  |  |  |  |  |  |  |  |  |  |  |  |  |  |
| XC201305 |  | CA13 AgitatorRemUnit - Concrete Works Foundation |  | 225d | 2010-10-04 A | 2011-12-05 | E-22206 FF+30d, EC281305 (other project) FS+5d, E-21206 FF+30d, XC201300 FS+50d, XC201232 SS+6d, EC45130515 (other project) FS+20d, EC45130505 (other project), XN201301u FF+18d | 100% | 20d | 2010-10-04 | 2011-08-31 | -41d | 0d |  | TB26 - V - Construct-Winter partly * | Concrete works [130 cbm]; Concrete works [3900 h] |  |  | 3900,00 | 27.8. | XC201305 | 3900 | 600 | x | 934 | 13 | 200 | 200 | C | MO03 | X | C | XC20 | 1305 | C | 13 | X | mis | LND | 1305 | MO11 |  |  | x |  |  |  |  |  |  |  |  |  |  |  |  |  |  |  |  |  |
|  | N | **Structural Steel** |  |  | 2011-02-28 | 2012-03-07 |  |  |  |  |  |  |  |  |  |  |  |  |  |  |  |  |  |  |  |  |  |  |  |  |  |  |  |  |  |  |  |  |  |  |  |  |  |  |  |  |  |  |  |  |  |  |  |  |  |  |  |  |  |  |  |
| XN701305 |  | CA13 AgitatorRemUnit SK1305 - KMD Assy Drawings | milestone | 0d | 2011-02-28 A | 2011-02-28 A |  | 100% |  |  |  |  |  | finish on 2011-02-27 | TB26 - V - Construct-Winter partly * |  |  |  | 22t |  | XN701305 | 0 | 0 |  | 934 | 13 | 200 | 200 | C | LND | X | N | XN05 | 1305 | N | 13 | X | SS | LND | 1305 |  |  |  |  | x | XNK | KMD |  |  |  |  |  |  |  |  |  |  |  |  |  |  |
| XN711305 |  | CA13 AgitatorRemUnit SK1305 - Steel Deliveries | milestone | 0d | 2011-09-20 | 2011-09-20 |  |  |  |  |  | 0d | 66d | finish on 2011-09-19 | TB26 - 3 - Construction Normal 7days * CA17 |  |  |  | 22t |  | XN711305 | 0 | 0 |  | 934 | 13 | 200 | 200 | C | LND | X | N | XN06 | 1305 | N | 13 | X | SS | LND | 1305 |  |  |  |  |  | XNK | SD |  |  |  |  |  |  |  |  |  |  |  |  |  |  |
| XN201305 |  | CA13 AgitatorRemUnit SK1305 - Erection Primary Steel |  | 20d | 2011-12-06 | 2012-01-25 | XB30130110 FS+10d, XN201304, XC201305, P3N02JN (other project), XN711305 FS+10d, XN701305, P3N012D (other project) FS+10d |  |  |  |  | 298.5d | 0d |  | TB26 - V - Construct-Winter partly * | Piperacks, Main Structures [117 t]; Piperacks, Main structures [4972.5 h] | 1,389.49 |  | 4972,50 |  | XN201305 | 4972,5 | 0 |  | 934 | 13 | 200 | 200 | C | LND | X | N | XN20 | 1305 | N | 13 | X | SS | LND | 1305 | ChSK | 2011-03-10 | E-04-07 |  |  | XNK |  | 2011-02-20 | t | x |  |  |  |  |  |  |  |  |  |  |  |
| XN401305 |  | CA13 AgitatorRemUnit SK1305 - Install Railing, Ladders |  | 10d | 2012-01-30 | 2012-02-20 | XN201305 |  |  |  |  | 298.5d | 0d |  | TB26 - V - Construct-Winter partly * | Ladders & platforms [8 t]; Ladders & platforms [800 h] | 362.15 |  | 800,00 |  | XN401305 | 800 | 0 |  | 934 | 13 | 200 | 200 | C | LND | X | N | XN40 | 1305 | N | 13 | X | SS | LND | 1305 | ChSK |  |  |  |  | XNK |  |  |  |  |  |  |  |  |  |  |  |  |  |  |  |
| XN601305 |  | CA13 AgitatorRemUnit SK1305 - Install Gratings |  | 20d | 2012-01-30 | 2012-03-07 | XN401305 SS, PN691305 (other project) |  |  |  |  | 298.5d | 0d |  | TB26 - V - Construct-Winter partly * | Grating [230 sqm]; Grating [862.5 h] | 13,451.4 |  | 862,50 |  | XN601305 | 862,5 | 0 |  | 934 | 13 | 200 | 200 | C | LND | X | N | XN60 | 1305 | N | 13 | X | SS | LND | 1305 | ChSK |  |  |  |  | XNK |  |  |  |  |  |  |  |  |  |  |  |  |  |  |  |
|  | H | **HVAC** |  |  |  |  |  |  |  |  |  |  |  |  |  |  |  |  |  |  |  |  |  |  |  |  |  |  |  |  |  |  |  |  |  |  |  |  |  |  |  |  |  |  |  |  |  |  |  |  |  |  |  |  |  |  |  |  |  |  |  |
|  | U | **Package Units** |  |  |  |  |  |  |  |  |  |  |  |  |  |  |  |  |  |  |  |  |  |  |  |  |  |  |  |  |  |  |  |  |  |  |  |  |  |  |  |  |  |  |  |  |  |  |  |  |  |  |  |  |  |  |  |  |  |  |  |
|  | B | **Mechanical - Stationary Equipment** |  |  |  |  |  |  |  |  |  |  |  |  |  |  |  |  |  |  |  |  |  |  |  |  |  |  |  |  |  |  |  |  |  |  |  |  |  |  |  |  |  |  |  |  |  |  |  |  |  |  |  |  |  |  |  |  |  |  |  |
|  | M | **Mechanical - Rotating Equipment** |  |  |  |  |  |  |  |  |  |  |  |  |  |  |  |  |  |  |  |  |  |  |  |  |  |  |  |  |  |  |  |  |  |  |  |  |  |  |  |  |  |  |  |  |  |  |  |  |  |  |  |  |  |  |  |  |  |  |  |
|  | R | **Piping** |  |  |  |  |  |  |  |  |  |  |  |  |  |  |  |  |  |  |  |  |  |  |  |  |  |  |  |  |  |  |  |  |  |  |  |  |  |  |  |  |  |  |  |  |  |  |  |  |  |  |  |  |  |  |  |  |  |  |  |
|  | E | **Electrical** |  |  |  |  |  |  |  |  |  |  |  |  |  |  |  |  |  |  |  |  |  |  |  |  |  |  |  |  |  |  |  |  |  |  |  |  |  |  |  |  |  |  |  |  |  |  |  |  |  |  |  |  |  |  |  |  |  |  |  |
|  | J | **Instrumentation** |  |  | 2012-03-09 | 2012-04-06 |  |  |  |  |  |  |  |  |  |  |  |  |  |  |  |  |  |  |  |  |  |  |  |  |  |  |  |  |  |  |  |  |  |  |  |  |  |  |  |  |  |  |  |  |  |  |  |  |  |  |  |  |  |  |  |
| XJ381330 |  | CA13 AgitatorRemUnit - Install Analyser House |  | 25d | 2012-03-09 | 2012-04-06 | P3J07S2 (other project), XN601305, XJ381230 SS |  |  |  |  | 301.5d |  |  |  |  |  |  |  |  | XJ381330 | 0 | 0 |  | 934 | 13 | 200 | 200 | C | LND | X | J | XJ38 | 1305 | J | 13 | X | IN | LND | 1305 | URMA | 2012-03-20 | E-17-04-05 |  |  |  |  | 2011-05-10 |  |  | 2012-08-15 | 2011-07-25 | to be checked |  |  |  |  |  |  |  |  |
|  | S | **Safety & Environment** |  |  |  |  |  |  |  |  |  |  |  |  |  |  |  |  |  |  |  |  |  |  |  |  |  |  |  |  |  |  |  |  |  |  |  |  |  |  |  |  |  |  |  |  |  |  |  |  |  |  |  |  |  |  |  |  |  |  |  |
|  | W | **Painting** |  |  |  |  |  |  |  |  |  |  |  |  |  |  |  |  |  |  |  |  |  |  |  |  |  |  |  |  |  |  |  |  |  |  |  |  |  |  |  |  |  |  |  |  |  |  |  |  |  |  |  |  |  |  |  |  |  |  |  |
|  | V | **Insulation** |  |  |  |  |  |  |  |  |  |  |  |  |  |  |  |  |  |  |  |  |  |  |  |  |  |  |  |  |  |  |  |  |  |  |  |  |  |  |  |  |  |  |  |  |  |  |  |  |  |  |  |  |  |  |  |  |  |  |  |
|  | 21 | **CA13 - Catalyst Building Line 2** |  |  | 2010-09-17 | 2012-11-17 |  |  |  |  |  |  |  |  |  |  |  |  |  |  |  |  |  |  |  |  |  |  |  |  |  |  |  |  |  |  |  |  |  |  |  |  |  |  |  |  |  |  |  |  |  |  |  |  |  |  |  |  |  |  |  |
|  | C | **Civil Work** |  |  | 2010-09-17 | 2012-07-14 |  |  |  |  |  |  |  |  |  |  |  |  |  |  |  |  |  |  |  |  |  |  |  |  |  |  |  |  |  |  |  |  |  |  |  |  |  |  |  |  |  |  |  |  |  |  |  |  |  |  |  |  |  |  |  |
| XC20132105 |  | CA13 Catalyst Bldg - Concrete Works Building Fdtn |  | 243d | 2010-09-17 A | 2011-07-27 A | XC151300, XC201300 FS+40d, EC48132103 (other project) FS+10d | 100% |  | 2010-09-17 | 2011-09-05 |  |  |  | TB26 - V - Construct-Winter partly * | Concrete works [50 cbm]; Concrete works [1500 h] | 59,999.96 | 57,600 | 1500,00 |  | XC20132105 | 1500 | 1440 |  | 934 | 13 | 200 | 200 | C | MO03 | X | C | XC20 | 1321 | C | 13 | X | OB | LND | 1321 | MO11 |  |  | x |  |  |  |  |  |  |  |  |  | UDF_G4 |  |  |  |  |  |  |  |
| XC401321 |  | CA13 Catalyst Bldg SK1306 - Concrete Works Building |  | 208d | 2010-10-28 A | 2011-12-28 | EC48132120 (other project) FF+20d, IMS-C-000110 FF, P3C02D2 (other project), XC401221 SS+10d, XC20132105 FS+10d, EC48132105 (other project) FS+20d, EC48132110 (other project) FF+20d, EC48132115 (other project) FF+20d |  | 86d | 2010-10-28 | 2011-09-05 | -52d | 0d |  | TB26 - V - Construct-Winter partly * | Concrete works [340 cbm]; Concrete works [10200 h] | 5,912.7 |  | 10200,00 | 27.8. | XC401321 | 10200 | 3000 | x | 934 | 13 | 200 | 200 | C | MO04 | X | C | XC40 | 1321 | C | 13 | X | OB | LND | 1321 | MO11 |  |  | x |  |  |  |  |  | x |  |  |  | UDF_G4 | SK1306 | XJ321321 |  |  |  |  |  |
| XC201321 |  | CA13 Catalyst Bldg - Concrete Works EqptFdtn |  | 20d | 2011-11-17 | 2011-12-28 | EC281321 (other project) FS+20d, XC401321 FF, IMS-C-000060 FF, EC45132105 (other project), XC20132105 FF, EC45132115 (other project) FS+20d, EC701321 (other project) FF |  |  |  |  | -44d | 0d | as late as possible | TB26 - V - Construct-Winter partly * | Concrete works [50 cbm]; Concrete works [1500 h] | 923.86 |  | 1500,00 | 27.8. | XC201321 | 1500 | 0 |  | 934 | 13 | 200 | 200 | C | MO04 | X | C | XC20 | 1321 | C | 13 | X | mis | LND | 1321 | MO11 |  |  |  |  |  |  |  |  |  |  |  |  |  | SK1306 |  |  |  |  |  |  |
| XC40132110 |  | CA13 Catalyst Bldg - Concrete Works Building finished | milestone | 0d | 2011-12-28 | 2011-12-28 | IMS-C-000110 FF, XC401321 FF |  |  |  |  | -25d | 0d |  | TB26 - V - Construct-Winter partly * |  |  |  |  |  | XC40132110 | 0 | 0 |  | 934 | 13 | 200 | 200 | C | MO04 | X | C | XC40 | 1321 | C | 11 | X | OB | LND | 1110 | MO11 |  |  |  |  |  | D |  |  |  |  |  |  |  | SK1306 |  | 2011-06-27 | 2011-06-27 |  |  |  |
| XC501321 |  | CA13 Catalyst Bldg - Finishing Works Rooms |  | 120d | 2012-02-21 | 2012-07-14 | XC401321, XC510C00 FS+15d, EC501321 (other project), XN801321 SS+10d, XC911321 FF+20d, XC001321 FF, XC40132110 |  |  |  |  | -10d | 0d |  |  | Finishing Works - Catalyst Buildings CA12/13 [31282 mhr]; Finishing Works - Catalyst buildings [31281 h] | 3,128,200 |  | 31282,00 |  | XC501321 | 31281 | 0 |  | 934 | 13 | 200 | 200 | C | CiC | X | C | XC50 | 1321 | C | 13 | X | OB | LND | 1321 |  |  |  |  |  |  |  |  |  |  |  |  |  |  |  | XJ321321 |  |  | 1 | x | XC50 |
| XC501321_1 |  | CA13 Catalyst Bldg - Plastering and Painting (Finishing Works) |  | 25d | 2012-02-21 | 2012-03-22 | XC501321 SS |  |  |  |  | -10d | 0d |  |  |  |  |  | 31282,00 |  | XC501321 | 31281 | 0 |  | 934 | 13 | 200 | 200 | C | CiC | X | C | XC50 | 1321 | C | 13 | X | OB | LND | 1321 |  |  |  |  |  |  |  |  |  |  |  |  |  |  |  |  |  |  | 1 | x |  |

Notes:
- XW501304: P3 Activity Log Info: Clarification Surface / Protection during Prefab
- XN711305: Scope: 09.02.2011: weight: 110 ton - Jan 3 ton; Feb 107 ton
- XC401321: Current Status: 110303 (WL) Resume Date 11.04.11 nach Vorgabe H. Bucher / 12.01.2011 (Oxana): eine Unterbrechung zw. 01.12.2010 und 11.01.2011 / eingebaut (Keine Zuordnung des kalenders, sondern eine Unterbrechung). / Enddatum 01.03.2011 (nach Abstimmung mit Mostostroy am 11.01.2011).
- XC40132110: P3 Activity Log Info: excl. openings for / Compressor Lifts
- XC501321: Current Status: 13.01.11 - Volkmann - analog CA12
- XC501321_1: Current Status: 13.01.11 - Volkmann - analog CA12

| ID | WBS | Activity | Type | Duration | Start | Finish | Predecessors | Complete | Remaining | Total float | Free float | Constraint | Calendar | Resources | Cost | TB26 Ressource Budget | UDF_SAVE ACT ID | UDF_CHECK BASELINE | UDF_BUDGETED LABOR UNIT | UDF_ACTUAL LABOR UNIT | Department | Type of Work | Constr. Area | PMT-Area | PMT-Schedule Org | PMT-Phase | PMT-Respons. | Zeigen/n. Zeigen | WBS Phase | WBS Discipline | WBS Type of Work | WBS Objects | Russia WBS Discipline (Russia) | Russia Construction Area | Russia WBS Phase | IMS | UPT | Russia WBS Objects | UDF_SELECT UPDATE PROGRESS | TB26 Semantics | UDF_ELECTRICAL SEQUENCE | Inquiry/Order No | Subcontractor | UDF_CHECK CRITICAL PATH | Filter | UDF_SELECT | UDF_CONTRACT START DATE | UDF_CONTRACT FINISH DATE | UDF_L3 START DATE | UDF_L3 FINISH DATE | UDF_Weight (ton) | WEIGHT | UDF_LEVEL | UDF_PO No | UDF_TAG No | UDF_Object No | UDF_DELIVERY DATE PO | UDF_DELIVERY DATE DISPATCH PLANNED | UDF_DELIVERY DATE TO SITE PLANNED | UDF_DELIVERY DATE SITE NEED DATE | UDF_PACKAGE | UDF_SUPPLIER | UDF_CONTRACT ITEM | UDF_CONTRACT INDICATOR | UDF_CHECK RESOURCE DATES | UDF_PLANNED START | UDF_PLANNED FINISH |
| --- | --- | --- | --- | --- | --- | --- | --- | --- | --- | --- | --- | --- | --- | --- | --- | --- | --- | --- | --- | --- | --- | --- | --- | --- | --- | --- | --- | --- | --- | --- | --- | --- | --- | --- | --- | --- | --- | --- | --- | --- | --- | --- | --- | --- | --- | --- | --- | --- | --- | --- | --- | --- | --- | --- | --- | --- | --- | --- | --- | --- | --- | --- | --- | --- | --- | --- | --- |
|  | N | **Structural Steel** |  |  | 2011-04-11 | 2012-03-16 |  |  |  |  |  |  |  |  |  |  |  |  |  |  |  |  |  |  |  |  |  |  |  |  |  |  |  |  |  |  |  |  |  |  |  |  |  |  |  |  |  |  |  |  |  |  |  |  |  |  |  |  |  |  |  |  |  |  |  |  |  |
| XN701306 |  | CA13 Catalyst Bldg SK1306 - KMD Assy Drawings | milestone | 0d | 2011-04-11 A | 2011-04-11 A |  | 100% |  |  |  | finish on 2011-04-11 | TB26 - V - Construct-Winter partly * |  |  | 22t | XN701306 | x | 0 | 0 | 934 | XNK | 13 | 200 | 200 | C | LND | KMD | X | N | XN05 | 1321 | N | 13 | X | SS | LND | 1321 |  |  |  |  |  |  |  |  |  |  |  |  |  |  |  |  |  |  |  |  |  |  |  |  |  |  |  |  |  |
| XN711306 |  | CA13 Catalyst Bldg SK1306 - Steel Deliveries | milestone | 0d | 2011-08-02 A | 2011-08-02 A |  | 100% |  |  |  | finish on 2011-08-01 | TB26 - 3 - Construction Normal 7days * CA17 |  |  | 22t | XN711306 |  | 0 | 0 | 934 | XNK | 13 | 200 | 200 | C | LND | SD | X | N | XN06 | 1321 | N | 13 | X | SS | LND | 1321 | 27.8. |  |  |  |  |  |  |  |  |  |  |  |  |  |  |  |  |  |  |  |  |  |  |  |  |  |  |  |  |
| XN301321 |  | CA13 Catalyst Bldg SK1306 - Install Prim Stelle / Eqpt Platforms |  | 20d | 2012-01-17 | 2012-02-08 | XN711306 FS+10d, V-22106 SS+10d, XN701306, V-22103 SS+10d, P3N02$N (other project), XC401321 FS-30d |  |  | -63d | 0d |  |  | Piperacks, Main Structures [32 t]; Piperacks, Main structures [1360 h] | 54,400 | 1360,00 | XN301321 |  | 1360 | 0 | 934 | XNK | 13 | 200 | 200 | C | LND |  | X | N | XN30 | 1321 | N | 13 | X | SS | LND | 1321 |  | t | XJ321321 | 2DC8460 | ChSK |  |  |  |  |  |  |  |  |  |  |  |  |  |  |  |  |  |  |  |  |  |  |  |  |
| XN401321 |  | CA13 Catalyst Bldg SK1306 - Install Railings,Ladders,etc. |  | 25d | 2012-02-09 | 2012-03-10 | XN301321 SS+20d |  |  | 324.5d | 0d |  |  | Ladders & platforms [3 t]; Ladders & platforms [300 h] | 12,000 | 300,00 | XN401321 |  | 300 | 0 | 934 | XNK | 13 | 200 | 200 | C | LND |  | X | N | XN40 | 1321 | N | 13 | X | SS | LND | 1321 |  |  |  |  | ChSK |  |  |  |  |  |  |  |  |  |  |  |  |  |  |  |  |  |  |  |  |  |  |  |  |
| XN801321 |  | CA13 Catalyst Bldg SK1306 - Cladding Works Walls/Roof |  | 30d | 2012-02-09 | 2012-03-16 | P3N02$N (other project), XN301321 |  |  | -53d | 0d | start on or after 2011-10-31 |  | Cladding [800 sqm]; Cladding [4000 h] | 160,000 | 4000,00 | XN801321 |  | 4000 | 0 | 934 | XNK | 13 | 200 | 200 | C | LND | D | X | N | XN80 | 1321 | N | 13 | X | SS | LND | 1321 |  |  | XJ321321 |  | ChSK | SK1306 |  |  |  |  |  |  |  |  |  |  |  |  |  |  |  |  |  |  |  |  |  |  |  |
| XN601321 |  | CA13 Catalyst Bldg SK1306 - Install Gratings |  | 20d | 2012-02-15 | 2012-03-10 | XN401321 FF |  |  | 324.5d |  |  |  | Grating [120 sqm]; Grating [450 h] | 18,000 | 450,00 | XN601321 |  | 450 | 0 | 934 | XNK | 13 | 200 | 200 | C | LND |  | X | N | XN60 | 1321 | N | 13 | X | SS | LND | 1321 |  |  |  |  | ChSK |  |  |  |  |  |  |  |  |  |  |  |  |  |  |  |  |  |  |  |  |  |  |  |  |
|  | H | **HVAC** |  |  | 2012-03-23 | 2012-09-05 |  |  |  |  |  |  |  |  |  |  |  |  |  |  |  |  |  |  |  |  |  |  |  |  |  |  |  |  |  |  |  |  |  |  |  |  |  |  |  |  |  |  |  |  |  |  |  |  |  |  |  |  |  |  |  |  |  |  |  |  |  |
| XH00132105 |  | CA13 Catalyst Bldg - Installation HVAC |  | 80d | 2012-03-23 | 2012-06-27 | EH30132105 (other project), XN301321, XH000000 FF, P3H01SF (other project), XC40132110 SS+19d, XC501321_1 |  |  | -10d | 0d |  |  | HVAC - Catalyst Buildings CA12/13 [9344 mhr]; HVAC - Catalyst buildings [9344 h] |  | 9343,00 | XH00132105 |  | 9344 | 0 | 934 |  | 13 | 200 | 200 | C | LND |  | X | H | XH00 | 1321 | H | 13 | X | hvac | LND | 1321 |  |  | XJ321321 |  | ARMO | SK1306 | x | REL XC50 | 2011-03-10 | 2011-05-30 | 2011-04-11 | 2011-07-02 |  |  |  |  |  |  |  |  |  |  |  |  |  |  |  |  |  |
| XH00132110 |  | CA13 Catalyst Bldg - Testing/Commissng HVAC (Start w. temp. Power) |  | 60d | 2012-06-28 | 2012-09-05 | XH000C10, X0300008 FS+20d, X0300080, XH00132105 |  |  | -10d | 0d |  |  |  |  |  | XH00132110 |  | 0 | 0 | 934 |  | 13 | 200 | 200 | C | LND |  | X | H | XH20 | 1321 | H | 13 | X | hvac | LND | 1321 |  |  |  |  | ARMO | SK1306 |  |  |  |  | 2011-09-05 | 2011-10-31 |  |  |  |  |  |  |  |  |  |  |  |  |  |  |  |  |  |
| XH00132107 |  | CA13 Catalyst Bldg - HVAC ready for Heating | milestone | 0d | 2012-07-10 | 2012-07-10 | XH00132110 SS+10d |  |  | 224.5d | 40.5d |  |  |  |  | 3809 | XH00132107 |  | 0 | 0 | 934 |  | 13 | 200 | 200 | C | LND |  | X | H | XH00 | 1321 | H | 13 | X | hvac | LND | 1321 |  |  |  |  | ARMO | SK1306 |  |  |  |  | 2011-09-16 | 2011-09-16 |  |  |  |  |  |  |  |  |  |  |  |  |  |  |  |  |  |
|  | U | **Package Units** |  |  |  |  |  |  |  |  |  |  |  |  |  |  |  |  |  |  |  |  |  |  |  |  |  |  |  |  |  |  |  |  |  |  |  |  |  |  |  |  |  |  |  |  |  |  |  |  |  |  |  |  |  |  |  |  |  |  |  |  |  |  |  |  |  |
|  | B | **Mechanical - Stationary Equipment** |  |  |  |  |  |  |  |  |  |  |  |  |  |  |  |  |  |  |  |  |  |  |  |  |  |  |  |  |  |  |  |  |  |  |  |  |  |  |  |  |  |  |  |  |  |  |  |  |  |  |  |  |  |  |  |  |  |  |  |  |  |  |  |  |  |
|  | M | **Mechanical - Rotating Equipment** |  |  | 2011-12-29 | 2012-02-27 |  |  |  |  |  |  |  |  |  |  |  |  |  |  |  |  |  |  |  |  |  |  |  |  |  |  |  |  |  |  |  |  |  |  |  |  |  |  |  |  |  |  |  |  |  |  |  |  |  |  |  |  |  |  |  |  |  |  |  |  |  |
| V-22103 |  | PRESSURE EQUIPMENT (Alternative Modifier Drum) |  | 10d | 2011-12-29 | 2012-01-16 | P3A01S2 (other project), XC20132105, XC201321, XB001321 SS, XB001321 FF |  |  | -63d | 0d |  |  | Static Equipment < 10 tons [1.8 t]; Static equipment < 10t [180 h] | 7,200 | 180,00 | V-22103 | x | 180 | 0 |  |  | 13 |  |  |  |  | EQ | X | B |  | 1321 |  |  |  |  |  |  |  |  |  |  | VNZM |  |  |  |  |  |  |  | 1,8 | 1800 | concrete +0.00 | 2 DD 8530 | V-22103 | SK1321 | 2010-10-02 | 2010-11-30 | 2011-02-10 | 2010-12-23 | A01 PRESSURE EQUIPMENT | GMM Pfaudler |  |  |  |  |  |
| XB001321 |  | CA13 Catalyst Bldg - Install Static Eqpt | level of effort | 45d | 2011-12-29 | 2012-02-27 |  |  |  | -58d | 0d |  |  |  |  | 7 | XB001321 |  | 0 | 0 | 934 | XBB | 13 | 200 | 200 | C | LND |  | X | B | XB00 | 1321 | B | 13 | X | EQ | LND | 1321 |  |  |  |  | VNZM | SK1306 |  |  | 2011-03-10 | 2011-05-20 |  |  |  |  |  |  |  |  |  |  |  |  |  |  | E-08-01-10 |  |  |  |  |
| P-22101A/B |  | CATALYST FEED PUMPS |  | 15d | 2012-02-09 | 2012-02-27 | P3M07S2 (other project), XM001321 SS, XM001321 FF, XC20132105, XN301321 |  |  | -58d | 0d |  |  | Rotating Equipment (w/o lube oil unit) [5.64 t]; Rotating equipment (w/o lube oil unit) [564.1 h] | 19,743.5 | 564,10 | P-22101A/B |  | 564,1 | 0 |  |  | 13 |  |  |  |  | EQ | X | M |  | 1321 |  |  |  |  |  |  |  |  | XJ321321 |  | VNZM |  |  |  |  |  |  |  | 0,87 | 435 | concrete +6.85 | 2 PA 667 | P-22101A/B | SK1321 | 2010-10-15 | 2010-11-30 | 2010-12-15 | 2010-12-20 | M07 CATALYST FEED PUMPS (P-21-/22101A/B) | Netzsch |  |  |  |  |  |
| V-22101 |  | PRESSURE EQUIPMENT (Catalyst Hold Drum) |  | 10d | 2012-02-09 | 2012-02-20 | XN301321, XB001321 SS, XB001321 FF, V-22106, P3A01S2 (other project), V-22103 |  |  | -58d | 0d |  |  | Static Equipment < 10 tons [0.8 t]; Static equipment < 10t [80 h] | 3,200 | 80,00 | V-22101 | x | 80 | 0 |  |  | 13 |  |  |  |  | EQ | X | B |  | 1321 |  |  |  |  |  |  |  |  |  |  | VNZM |  |  |  |  |  |  |  | 0,8 | 800 | structure +10.85 | 2 DD 8530 | V-22101 | SK1321 | 2010-10-02 | 2010-11-30 | 2011-02-10 | 2010-12-23 | A01 PRESSURE EQUIPMENT | GMM Pfaudler |  |  |  |  |  |
| XM001321 |  | CA13 Catalyst Bldg - Install Rotating Eqpt | level of effort | 15d | 2012-02-09 | 2012-02-27 |  |  |  | -58d | 0d |  |  |  |  | 1 | XM001321 |  | 0 | 0 | 934 |  | 13 |  |  |  | LND |  | X | M | XM00 | 1321 | M | 13 | X | EQ | LND | 1321 |  |  |  |  | VNZM | SK1306 |  |  | 2011-03-10 | 2011-05-20 |  |  |  |  |  |  |  |  |  |  |  |  |  |  | E-08-01-10 |  |  |  |  |
|  | R | **Piping** |  |  | 2011-07-18 | 2012-05-03 |  |  |  |  |  |  |  |  |  |  |  |  |  |  |  |  |  |  |  |  |  |  |  |  |  |  |  |  |  |  |  |  |  |  |  |  |  |  |  |  |  |  |  |  |  |  |  |  |  |  |  |  |  |  |  |  |  |  |  |  |  |
| XR201321 |  | CA13 Catalyst Bldg SK1306 - Piping Prefabrication |  | 71d | 2011-07-18 A | 2011-10-07 | ER491321 (other project) SS+18d, XR200C00 |  | 36d | 67d | 448.5d |  |  | A/G piping prefabrication [810 Fpi]; A/G Piping (Prefab) [3037.5 h] | 2,838.1 | 3037,50 | XR201321 |  | 3037,5 | 0 | 934 |  | 13 | 200 | 200 | C | LND |  | X | R | XR20 | 1321 | R | 13 | X | PRP | LND | 1321 | 27.8. |  |  |  | VNZM |  |  |  |  |  |  |  |  |  |  |  |  |  |  |  |  |  |  |  |  | UDF_G4 | x |  |  |
| XR401321 |  | CA13 Catalyst Bldg SK1306 - Piping Installation |  | 40d | 2012-02-09 | 2012-03-28 | P3A25S (other project) FF+20d, P3J02S (other project) FF+20d, P-22106 SS, V-22106 SS+10d, P3J02AS (other project), P-22107 SS, P3J04CS1 (other project), MI-22101 SS+10d, P-22103 A/B SS, P3R04AS (other project), P3J01AS (other project) FF+20d, P-22108 SS, V-22103 SS+10d, P3J02DS (other project), XN301321, HO-22207, P-22104 SS, XR201321 SS+40d, P3J04IS (other project) FF+20d |  |  | -63d | 0d |  |  | A/G piping field installation [990 Fpi]; Control & Shut-off valves [26 pcs]; A/G Piping (Field) [6187.5 h]; Install Control & Shut-off Valves [136.5 h] | 15,555.94 | 6324,00 | XR401321 |  | 6324 | 0 | 934 |  | 13 | 200 | 200 | C | LND |  | X | R | XR40 | 1321 | R | 13 | X | PI | LND | 1321 |  |  | XJ321321 |  | VNZM |  |  |  | 2011-01-20 |  |  |  |  |  |  |  |  |  |  |  |  |  |  |  | E-06-03-04 |  |  | 2011-03-30 |  |
| XR601321 |  | CA13 Catalyst Bldg SK1306 - Piping Pressure Tests |  | 20d | 2012-03-29 | 2012-04-20 | XR605103 FF+21d, XR401321 FF+20d, X0300020 |  |  | -7d | 0d |  |  |  |  | 225 | XR601321 |  | 0 | 0 | 934 |  | 13 | 200 | 200 | C | LND |  | X | R | XR60 | 1321 | R | 13 | X | HY | LND | 1321 |  |  |  |  | VNZM | SK1306 |  |  |  |  |  |  |  |  |  |  |  |  |  |  |  |  |  |  | E-06-03-04 |  |  |  |  |
| XR801321 |  | CA13 Catalyst Bldg SK1306 - Piping Reinstatement |  | 10d | 2012-04-21 | 2012-05-03 | XR601321 FF+10d, IMS-C-000360 FF |  |  | -7d | 30d |  |  |  |  | 113 | XR801321 |  | 0 | 0 | 934 |  | 13 | 200 | 200 | C | LND |  | X | R | XR80 | 1321 | R | 13 | X | PI | LND | 1321 |  |  | XJ321321 |  | VNZM | SK1306 |  |  |  | 2011-11-30 |  |  |  |  |  |  |  |  |  |  |  |  |  |  | E-06-03-04 |  |  |  | 2012-02-11 |

Notes:
- XN711306: Scope: 09.02.2011: weight: 50 ton - Mrz 50 ton
- XN801321: Current Status: 2110806 Delivery end of October 2011 (Info from Fr. Schilka 02.08.2011)
- XH00132110: Current Status: 21.01.2011 - Siegel - Vorgдnger zur IBN HVAC / Condensat, LP-Dampf, Kьhlwasser von FF + 30 Tage Lag auf FS + 0 geдndert!
- XB001321: Current Status: 110303 (WL) Add PRED XN301321 Install Prim Steel / Platforms; Delete PRED / XH00132105 Install HVAC
- XM001321: Current Status: 110303 (WL) Add PRED XN301321 Install Prim Steel / Platforms; Delete PRED / XH00132105 Install HVAC
- XR401321: Current Status: 110303 (WL) Delete PRED XN801321 Cladding Works / Walls/Roof / 110831: OD 100 > 40 (M. Siegel)
- XR601321: Current Status: 110831: OD 60 > 20 (M. Siegel)
- XR801321: Current Status: 110831: OD 40 > 10 (M. Siegel)

| ID | WBS | Activity | Duration | Start | Finish | Predecessors | Complete | Remaining | Total float | Free float | Calendar | Resources | Cost | Actual cost | TB26 Ressource Budget | UDF_CONTRACT START DATE | UDF_CONTRACT FINISH DATE | UDF_CONTRACT ITEM | UDF_SAVE ACT ID | UDF_BUDGETED LABOR UNIT | UDF_ACTUAL LABOR UNIT | Department | Constr. Area | PMT-Area | PMT-Schedule Org | PMT-Phase | PMT-Respons. | WBS Phase | WBS Discipline | WBS Type of Work | WBS Objects | Russia WBS Discipline (Russia) | Russia Construction Area | Russia WBS Phase | IMS | UPT | Russia WBS Objects | Subcontractor | UDF_CONTRACT INDICATOR | UDF_ELECTRICAL SEQUENCE | UDF_CONTRACT FINISH DATE REV1 | UDF_CONTRACT START DATE REV1 | TB26 Semantics | TB26 Material Res Values | UDF_ELECTRICAL START | UDF_ELECTRICAL FINISH | UDF_CHECK BASELINE | UDF_COMMENTS_0827 | UDF_CHECK CRITICAL PATH | UDF_Vendor Representatives | Filter | geplanter Start | geplantes Ende | UDF_PENALIZED FINISH | UDF_SELECT UPDATE PROGRESS | UDF_CHECK RESOURCE DATES |
| --- | --- | --- | --- | --- | --- | --- | --- | --- | --- | --- | --- | --- | --- | --- | --- | --- | --- | --- | --- | --- | --- | --- | --- | --- | --- | --- | --- | --- | --- | --- | --- | --- | --- | --- | --- | --- | --- | --- | --- | --- | --- | --- | --- | --- | --- | --- | --- | --- | --- | --- | --- | --- | --- | --- | --- | --- |
|  | E | **Electrical** |  | 2010-09-17 | 2012-09-22 |  |  |  |  |  |  |  |  |  |  |  |  |  |  |  |  |  |  |  |  |  |  |  |  |  |  |  |  |  |  |  |  |  |  |  |  |  |  |  |  |  |  |  |  |  |  |  |  |  |  |  |
| XC911321 |  | CA13 Catalyst Bldg - Install Earthing&Lightn.Sys_CIVIL | 35d | 2010-09-17 A | 2010-10-27 A | EE901321 (other project), XC20132105 FF+10d | 100% |  |  |  |  | Grounding & Lightning [100 pcs]; Grounding & Lightning [1125 h] | 45,000 | 45,000 | 1125,00 | 2011-05-10 | 2011-11-30 | E-16-07-05 | XC911321 | 1125 | 1125 | 934 | 13 | 200 | 200 | C | LND | X | C | XE91 | 1321 | C | 13 | X | EA | LND | 1321 | MO11 |  |  |  |  |  |  |  |  |  |  |  |  |  |  |  |  |  |  |
| XE911323 |  | CA13 Catalyst Bldg - Install Earthing&Lightn.Sys_E/I | 10d | 2012-02-28 | 2012-03-10 | XN301321, AG-22101, HO-22207, MI-22101, MI-22104 A/B, V-22101, V-22103, V-22106, P-22101A/B, P-22103 A/B, P-22104, P-22106, P-22107, P-22108 |  |  | 93d | 180d |  |  |  |  | 115 | 2011-05-10 | 2011-11-30 | E-16-07-05 | XE911323 | 0 | 0 | 934 | 13 | 200 | 200 | C | LND | X | E | XE91 | 1321 | E | 13 | X | EA | LND | 1321 | URMA | UDF_G3 | XJ321321 | 2012-04-15 | 2011-07-25 |  |  |  |  |  |  |  |  |  |  |  |  |  |  |
| XE401321 |  | CA13 Catalyst Bldg - Install Cable Trays | 40d | 2012-03-17 | 2012-05-03 | XN801321, XN301321, XR401321 SS+20d, EE46510120 (other project) FF, EE46132110 (other project) |  |  | -53d | 0d |  | Cable trays/conduits [310 m]; Cable trays [930 h] | 37,200 |  | 930,00 | 2011-05-10 | 2011-08-20 | E-15-01-09 | XE401321 | 930 | 0 | 934 | 13 | 200 | 200 | C | LND | X | E | XE40 | 1321 | E | 13 | X | EL | LND | 1321 | URMA | UDF_G3 | XJ321321 | 2011-12-20 | 2011-07-20 | m | 510 | 2011-06-18 | 2011-08-26 | x | to be checked |  |  |  |  |  |  |  |  |
| XE801321 |  | CA13 Catalyst Bldg - Install Heat Tracing | 30d | 2012-03-29 | 2012-05-03 | MI-22101 FS+42d, XW501321 FF+20d, P-22108, XE800C00 SS, P3E19S (other project), E3E1950 (other project), P-22102 A/B, PK-22211, CY-21202, XR401321, XR601321 FF+10d |  |  | -1d | 0d |  | Electrical Heat Tracing [1100 m]; Electrical heat tracing [550 h] | 22,000 |  | 550,00 | 2011-06-20 | 2012-03-20 | E-16-04-01 | XE801321 | 550 | 0 | 934 | 13 | 200 | 200 | C | LND | X | E | XE80 | 1321 | E | 13 | X | HT | LND | 1321 | URMA | UDF_G3 |  | 2012-06-30 | 2011-09-15 |  |  |  |  |  |  | SK1306 | 005 |  |  |  |  |  |  |
| XE701321 |  | CA13 Catalyst Bldg - Install Lighting&SmallPower | 60d | 2012-04-10 | 2012-06-21 | XE401321 SS+20d, XC401321, P3E09S (other project), XP341610 FS+50d, EE761321 (other project) |  |  | 8d | 20d |  | Cable Pulling [700 m]; Lighting illuminates [70 pcs]; Cable pulling [350 h]; Lighting (iluminates) [700 h] | 42,000 |  | 1050,00 | 2011-05-10 | 2012-01-31 | E-16-03-01 | XE701321 | 1050 | 0 | 934 | 13 | 200 | 200 | C | LND | X | E | XE70 | 1321 | E | 13 | X | EL | LND | 1321 | URMA |  | XJ321321 | 2012-05-10 | 2011-08-15 |  |  |  |  |  |  |  |  | x |  |  |  |  |  |
| XE341321 |  | CA13 Catalyst Bldg - Install Local Operation Panels | 20d | 2012-05-04 | 2012-05-28 | EE46132110 (other project), XE401321, XR401321 SS+20d, HO-22207, MI-22101, V-22106, V-22103, MI-22104 A/B, V-22101, AG-22101, P-22108, P-22107, P-22104, P-22106, P-22103 A/B, P-22101A/B |  |  | -5d | 66.5d |  | Field Panels [3 pcs]; Field panels [60 h] | 2,400 |  | 60,00 | 2011-05-10 | 2011-11-30 | E-16-07-05 | XE341321 | 60 | 0 | 934 | 13 | 200 | 200 | C | LND | X | E | XE34 | 1321 | E | 13 | X | EL | LND | 1321 | URMA | UDF_G3 | XJ321321 | 2012-04-15 | 2011-07-25 |  |  |  |  |  | to be checked |  |  |  |  |  |  |  |  |
| XE501321 |  | CA13 Catalyst Bldg - Cable Pulling Electric | 60d | 2012-06-18 | 2012-08-27 | XE501304 SS, XE505103 SS, XE500C01, EE561321 (other project), XE401321, XE505102 SS, XE505401 SS |  |  | -71.5d | 0d | TB26 - V - Construct-Winter partly * | Cable Pulling [5300 m]; Cable pulling [2650 h] | 106,000 |  | 2650,00 | 2011-05-20 | 2012-02-10 | E-16-01-01 | XE501321 | 2650 | 0 | 934 | 13 | 200 | 200 | C | LND | X | E | XE50 | 1321 | E | 13 | X | EL | LND | 1321 | URMA | UDF_G3 | XJ321321 | 2012-07-01 | 2011-10-01 | m | 5500 | 2011-09-10 | 2011-11-19 |  |  |  |  |  |  |  |  |  |  |
| XE601321 |  | CA13 Catalyst Bldg - Cable Termination & Testing | 50d | 2012-07-11 | 2012-09-07 | XE501321 FS-40d, XE341321 FF+20d, AG-22101, HO-22207, MI-22101, MI-22104 A/B, V-22101, V-22103, V-22106, P-22101A/B, P-22103 A/B, P-22104, P-22106, P-22107, P-22108 |  |  | -71.5d | 0d |  | Cable connecting [40 pcs]; Cable connecting [100 h] | 4,000 |  | 100,00 | 2011-04-20 | 2011-11-30 | E-16-02-01 | XE601321 | 100 | 0 | 934 | 13 | 200 | 200 | C | LND | X | E | XE60 | 1321 | E | 13 | X | ET | LND | 1321 | URMA | UDF_G3 | XJ321321 | 2012-08-14 | 2011-12-10 |  |  |  |  |  |  |  |  |  |  |  |  |  |  |
| XE921321 |  | CA13 Catalyst Bldg - Install Fire Detection Sys | 60d | 2012-07-16 | 2012-09-22 | XC501321, XE701321, XH00132105, XJ421321 |  |  | 159.5d | 0d |  | Fire Detection System; Fire detection system |  |  | 0,00 | 2011-05-10 | 2011-11-30 | E-16-07-05 | XE921321 | 0 | 0 | 934 | 13 | 200 | 200 | C | UIO | X | E | XE92 | 1321 | E | 13 | X | FGDS | LND | 1321 |  |  | XJ321321 |  |  |  |  |  |  | x |  |  |  | x | 2012-02-17 | 2012-07-13 |  |  |  |
| XE961321 |  | CA13 Catalyst Bldg - Install Communication Sys | 60d | 2012-07-16 | 2012-09-22 | P3E13S (other project), XC501321, XH00132105, XE701321, E3E1350 (other project), XE921321 SS, XJ421321 |  |  | 159.5d |  |  | Communication System |  |  | 0,00 | 2011-05-10 | 2011-11-30 | E-16-07-05 | XE961321 | 0 | 0 | 934 | 13 | 200 | 200 | C | LND | X | E | XE96 | 1321 | E | 13 | X | CS | LND | 1321 |  |  | XJ321321 |  |  |  |  |  |  | x |  |  |  | x | 2012-02-17 | 2012-07-13 |  |  |  |
|  | J | **Instrumentation** |  | 2012-03-05 | 2012-11-17 |  |  |  |  |  |  |  |  |  |  |  |  |  |  |  |  |  |  |  |  |  |  |  |  |  |  |  |  |  |  |  |  |  |  |  |  |  |  |  |  |  |  |  |  |  |  |  |  |  |  |  |
| XJ301321 |  | CA13 Catalyst Bldg - Install Field Instruments | 80d | 2012-03-05 | 2012-06-08 | XR801321 FF, P3J12DS (other project), P3J13CS (other project), P3J04ES (other project), P3J05S (other project), P3J14BS (other project), P3J04AS (other project), P3J12BS (other project), P3J07AS (other project), P3J13BS (other project), EJ361321 (other project), P3J13AS (other project), P3J04BS (other project), P3J13S (other project), P3J14AS (other project), P3J14S (other project), P3J12AS (other project), XR401321 SS+20d, AG-22101, HO-22207, MI-22101, MI-22104 A/B, V-22101, V-22103, V-22106, P-22101A/B, P-22103 A/B, P-22104, P-22106, P-22107, P-22108 |  |  | -37d | 0d |  | Field Instruments [140 pcs]; Install field instruments [770 h] | 30,800 |  | 770,00 | 2011-05-10 | 2012-03-20 | E-17-04-05 | XJ301321 | 770 | 0 | 934 | 13 | 200 | 200 | C | LND | X | J | XJ30 | 1321 | J | 13 | X | IN | LND | 1321 | URMA | UDF_G3 | XJ321321 | 2012-08-15 | 2011-07-25 |  |  |  |  |  | to be checked | SK1306 |  |  |  |  |  |  |  |
| XJ321321 |  | CA13 Catalyst Bldg - Install Junction Boxes | 40d | 2012-03-05 | 2012-04-20 | P3J06FS (other project) FF, EJ321321 (other project), MI-22104 A/B FF+10d, P3J06ES (other project) FS+14d, XR401321 FS-20d, AG-22101, HO-22207, MI-22101, MI-22104 A/B, V-22101, V-22103, V-22106, P-22101A/B, P-22103 A/B, P-22104, P-22106, P-22107, P-22108 |  |  | -63d | 0d |  | Junction Boxes/Cabinets/Panels [31 pcs]; Install Junction Boxes/ Cabinets/ Panels [775 h] | 31,000 |  | 775,00 | 2011-05-10 | 2012-03-20 | E-17-04-05 | XJ321321 | 775 | 0 | 934 | 13 | 200 | 200 | C | LND | X | J | XJ32 | 1321 | J | 13 | X | IN | LND | 1321 | URMA | UDF_G3 | XJ321321 | 2012-08-15 | 2011-07-25 |  |  |  |  |  | to be checked |  |  |  |  |  |  |  |  |
| XJ421321 |  | CA13 Catalyst Bldg - Install Secondary Cable Trays | 30d | 2012-04-10 | 2012-05-16 | XJ321321 FF+20d, XE401321 FF, EJ46132110 (other project), XR401321 SS+20d, AG-22101, HO-22207, MI-22101, MI-22104 A/B, V-22101, V-22103, V-22106, P-22101A/B, P-22103 A/B, P-22104, P-22106, P-22107, P-22108 |  |  | -63d | 0d |  | Secondary cable trays [260 m]; Install secondary cable trays [975 h] | 39,000 |  | 975,00 | 2011-05-10 | 2012-03-20 | E-17-04-05 | XJ421321 | 975 | 0 | 934 | 13 | 200 | 200 | C | LND | X | J | XJ42 | 1321 | J | 13 | X | IN | LND | 1321 | URMA |  | XJ321321 | 2012-08-15 | 2011-07-25 | m | 450 | 2011-06-18 | 2011-08-26 | x | to be checked |  |  | x |  |  |  |  |  |
| XJ441321 |  | CA13 Catalyst Bldg - Install Conduits to Instrm | 60d | 2012-05-17 | 2012-07-26 | XJ321321, AG-22101, HO-22207, MI-22101, MI-22104 A/B, V-22101, V-22103, V-22106, P-22101A/B, P-22103 A/B, P-22104, P-22106, P-22107, P-22108, XR401321 SS+20d, XE401321, XJ421321 |  |  | -63d | 0d |  |  |  |  |  | 2011-05-10 | 2012-03-20 | E-17-04-05 | XJ441321 | 0 | 0 | 934 | 13 | 200 | 200 | C | LND | X | J | XJ44 | 1321 | J | 13 | X | IN | LND | 1321 | URMA |  | XJ321321 | 2012-08-15 | 2011-07-25 |  |  |  |  |  | to be checked |  |  |  |  |  |  |  |  |
| XJ701321 |  | CA13 Catalyst Bldg - Instrument Tubing | 30d | 2012-05-29 | 2012-07-03 | XJ301321 FF+20d, XR401321 |  |  | -37d | 25d |  |  |  |  |  | 2011-05-10 | 2012-03-20 | E-17-04-05 | XJ701321 | 0 | 0 | 934 | 13 | 200 | 200 | C | LND | X | J | XJ70 | 1321 | J | 13 | X | IN | LND | 1321 | URMA |  | XJ321321 | 2012-08-15 | 2011-07-25 |  |  |  |  |  |  | SK1306 |  |  |  |  |  |  |  |
| XJ521321 |  | CA13 Catalyst Bldg - Pulling Multicore Cables | 50d | 2012-06-07 | 2012-08-06 | XJ525103 SS+12d, XE500C01, XJ521304 SS, XJ321321 SS+20d, XE401321, XJ525401 SS+18d, XJ525102 SS+15d, XJ525104 SS+10d |  |  | -18.5d | 0d | TB26 - V - Construct-Winter partly * | Multicore cables [5100 m]; Pull multicore cables [2550 h] | 102,000 |  | 2550,00 | 2011-05-20 | 2012-03-10 | E-17-01-01 | XJ521321 | 2550 | 0 | 934 | 13 | 200 | 200 | C | LND | X | J | XJ52 | 1321 | J | 13 | X | IN | LND | 1321 | URMA |  | XJ321321 | 2012-06-16 | 2011-11-01 | m | 3700 | 2011-09-24 | 2011-11-22 |  |  |  |  |  |  |  |  |  |  |
| XJ541321 |  | CA13 Catalyst Bldg - Pulling Singlecore Cables | 60d | 2012-06-09 | 2012-08-18 | XE500C01, EJ801321 (other project), XJ301321 FF+20d, XJ421321, XJ441321 SS+20d |  |  | -62d | 0d | TB26 - V - Construct-Winter partly * | Singlecore cables [12000 m]; Pull singlecore cables [9000 h] | 360,000 |  | 9000,00 | 2011-05-10 | 2012-03-20 | E-17-04-05 | XJ541321 | 9000 | 0 | 934 | 13 | 200 | 200 | C | LND | X | J | XJ54 | 1321 | J | 13 | X | IN | LND | 1321 | URMA |  | XJ321321 | 2012-08-15 | 2011-07-25 | m | 11900 | 2011-12-06 | 2012-02-08 |  |  |  |  |  |  |  |  |  |  |
| XJ391321 |  | CA13 Catalyst Bldg - Install Earthing Field Eqpt | 30d | 2012-06-22 | 2012-07-26 | XJ301321 FS-40d, XJ441321 FS-30d, XJ421321 FS-15d |  |  | -57d | 5d |  |  |  |  |  | 2011-05-10 | 2012-03-20 | E-17-04-05 | XJ391321 | 0 | 0 | 934 | 13 | 200 | 200 | C | LND | X | J | XJ39 | 1321 | J | 13 | X | IN | LND | 1321 | URMA |  | XJ321321 | 2012-08-15 | 2011-07-25 |  |  |  |  |  |  |  |  |  |  |  |  |  |  |
| XJ621321 |  | CA13 Catalyst Bldg - Termin Multicore Cables | 50d | 2012-06-26 | 2012-08-23 | XJ521321 FF+15d, XJ321321 |  |  | -18.5d | 53d |  | Termination Field [705 mhr]; Termination field [705 h] | 70,500 |  | 705,00 | 2011-05-20 | 2012-03-10 | E-17-01-01 | XJ621321 | 705 | 0 | 934 | 13 | 200 | 200 | C | LND | X | J | XJ62 | 1321 | J | 13 | X | IN | LND | 1321 | URMA |  | XJ321321 | 2012-06-16 | 2011-11-01 |  |  |  |  |  |  |  |  |  |  |  |  |  |  |
| XJ641321 |  | CA13 Catalyst Bldg - Termin Singlecore Cables | 50d | 2012-07-16 | 2012-09-11 | XJ701321 FS-15d, XJ541321 FS-30d, XJ391321 FS-15d, XJ301321 FS-40d, XJ321321 FS-20d |  |  | -62d | 25d |  | Termination Field [705 mhr]; Termination field [705 h] | 70,500 |  | 705,00 | 2011-05-10 | 2012-03-20 | E-17-04-05 | XJ641321 | 705 | 0 | 934 | 13 | 200 | 200 | C | LND | X | J | XJ64 | 1321 | J | 13 | X | IN | LND | 1321 | URMA |  | XJ321321 | 2012-08-15 | 2011-07-25 |  |  |  |  |  |  |  |  |  |  |  |  |  |  |
| XJ801321 |  | CA13 Catalyst Bldg - Inspections/ Mech. Acceptance/ Loop Checks | 60d | 2012-09-07 | 2012-11-17 | XE601321, XJ391321 SS+10d, EJ801321 (other project), X3J100 FF, X030410030, XJ701321 SS, X3J120, XJ641321 FF+20d, XJ621321 FF+20d |  |  | -71.5d | 24d |  | Loop Checks [350 pcs]; Loop checks [1750 h] | 70,000 |  | 1750,00 | 2011-06-10 | 2012-04-30 | E-17-02-01 | XJ801321 | 1750 | 0 | 934 | 13 | 200 | 200 | C | LND | X | J | XJ80 | 1321 | J | 13 | X | LT | LND | 1321 | URMA |  | XJ321321 | 2012-08-18 | 2012-03-01 |  |  |  |  |  |  |  |  |  |  |  | 2012-08-18 |  |  |
|  | S | **Safety & Environment** |  |  |  |  |  |  |  |  |  |  |  |  |  |  |  |  |  |  |  |  |  |  |  |  |  |  |  |  |  |  |  |  |  |  |  |  |  |  |  |  |  |  |  |  |  |  |  |  |  |  |  |  |  |  |
|  | W | **Painting** |  | 2011-08-10 | 2011-10-07 |  |  |  |  |  |  |  |  |  |  |  |  |  |  |  |  |  |  |  |  |  |  |  |  |  |  |  |  |  |  |  |  |  |  |  |  |  |  |  |  |  |  |  |  |  |  |  |  |  |  |  |
| XW501321 |  | CA13 Catalyst Bldg - Surf.Protection Piping | 51d | 2011-08-10 A | 2011-10-07 | XR201321 SS+20d |  | 36d | 148d | 149d |  | Piping painting [284 sqm]; Piping painting [710 h] | 372.5 |  | 710,00 |  |  |  | XW501321 | 710 | 0 | 934 | 13 | 200 | 200 | C | LND | X | W | XW50 | 1321 | W | 13 | X | PA | LND | 1321 | VNZM |  |  |  |  |  |  |  |  |  |  |  |  |  |  |  |  | 27.8. | ok |

Notes:
- XE911323: UDF_PREDECESSOR: XE401321, XJ421321, XN301321
- XE401321: UDF_PREDECESSOR: XN801321-SS+5, XN301321, XR401321-SS+5d
- XE701321: UDF_PREDECESSOR: XE401321-SS+20, XC401321
- XE341321: UDF_PREDECESSOR: XE401321-FF
- XE501321: UDF_PREDECESSOR: XE501304-SS+5, XE505103-SS+18, XE341321, XE401321
- XE601321: UDF_PREDECESSOR: XE501321-FF+20
- XE921321: Scope: CA13 Polymerization Line 2 / FDS - 49 external sensors / GDS - 26 external sensors / DS + SAME / UDF_PREDECESSOR: XC501321, XE701321, XH00132105, XJ421321
- XE961321: Scope: CA13 Polymerization Line 2 / FDS - 49 external sensors / GDS - 26 external sensors / DS + SAME / UDF_PREDECESSOR: XC501321, XH00132105, XE701321, XE921321-SS, XJ421321
- XJ301321: UDF_PREDECESSOR: XR801321-FF
- XJ321321: UDF_PREDECESSOR: V-22106-FF+10, P-22108-FF+10, P-22106-FF+10, P-22107-FF+10, V-22101-FF+10
- XJ421321: UDF_PREDECESSOR: XJ321321-FF+20, XE401321-FF
- XJ441321: UDF_PREDECESSOR: XJ321321
- XJ701321: UDF_PREDECESSOR: XJ301321-FF+20
- XJ521321: UDF_PREDECESSOR: XJ525103-SS+18, XJ521304-SS+18, XJ321321-SS+20
- XJ541321: UDF_PREDECESSOR: XJ301321-SS+10, XJ421321, XJ441321-FS-5, XJ621321-SS+6
- XJ391321: UDF_PREDECESSOR: XJ301321-FF+10, XJ321321-FF+10
- XJ621321: UDF_PREDECESSOR: XJ521321-FF+20
- XJ641321: UDF_PREDECESSOR: XJ701321-FF+20, XJ541321-FF+15, XJ391321
- XJ801321: UDF_PREDECESSOR: XE601321-FS-10, XJ391321, XJ701321-SS, XJ641321-FS-30
- XW501321: P3 Activity Log Info: Clarification Surface / Protection during Prefab

| ID | WBS | Activity | Type | Duration | Start | Finish | Predecessors | Complete | Planned start | Planned finish | Total float | Free float | Constraint | Calendar | Resources | Cost | Actual cost | TB26 Ressource Budget | UDF_CONTRACT FINISH DATE | UDF_CONTRACT ITEM | UDF_SAVE ACT ID | UDF_BUDGETED LABOR UNIT | UDF_ACTUAL LABOR UNIT | Department | Constr. Area | PMT-Area | PMT-Schedule Org | PMT-Phase | PMT-Respons. | WBS Phase | WBS Discipline | WBS Type of Work | WBS Objects | Russia WBS Discipline (Russia) | Russia Construction Area | Russia WBS Phase | IMS | UPT | Russia WBS Objects | Subcontractor | Civil item | UDF_CONTRACT INDICATOR | UDF_CHECK CRITICAL PATH | UDF_SELECT UPDATE PROGRESS | UDF_CHECK RESOURCE DATES | 4 week lookahead | UDF_EXPECTED START | UDF_EXPECTED FINISH | Zeigen/n. Zeigen | UDF_Concrete | UDF_SELECT | UDF_CHECK BASELINE | Type of Work | TB26 Semantics | Inquiry/Order No | Filter | UDF_CONTRACT START DATE | UDF_L3 START DATE | UDF_L3 FINISH DATE | UDF_Object No | UDF_Weight (ton) | WEIGHT | UDF_LEVEL | UDF_PO No | UDF_TAG No | UDF_DELIVERY DATE PO | UDF_DELIVERY DATE DISPATCH PLANNED | UDF_DELIVERY DATE TO SITE PLANNED | UDF_DELIVERY DATE SITE NEED DATE | UDF_PACKAGE | UDF_SUPPLIER |
| --- | --- | --- | --- | --- | --- | --- | --- | --- | --- | --- | --- | --- | --- | --- | --- | --- | --- | --- | --- | --- | --- | --- | --- | --- | --- | --- | --- | --- | --- | --- | --- | --- | --- | --- | --- | --- | --- | --- | --- | --- | --- | --- | --- | --- | --- | --- | --- | --- | --- | --- | --- | --- | --- | --- | --- | --- | --- | --- | --- | --- | --- | --- | --- | --- | --- | --- | --- | --- | --- | --- | --- |
|  | V | **Insulation** |  |  | 2012-04-17 | 2012-08-25 |  |  |  |  |  |  |  |  |  |  |  |  |  |  |  |  |  |  |  |  |  |  |  |  |  |  |  |  |  |  |  |  |  |  |  |  |  |  |  |  |  |  |  |  |  |  |  |  |  |  |  |  |  |  |  |  |  |  |  |  |  |  |  |  |  |
| XV501321 |  | CA13 Catalyst Bldg - Insulation Piping |  | 110d | 2012-04-17 | 2012-08-25 | XV301321 FF+6d, XE801321 FF+20d |  |  |  | -1d | 94.5d |  |  | Piping insulation [250 sqm]; Piping insulation [1875 h] | 1,064.29 |  | 1875,00 | 2012-04-30 | E-13-01 | XV501321 | 1875 | 0 | 934 | 13 | 200 | 200 | C | LND | X | V | XV50 | 1321 | V | 13 | X | INS | LND | 1321 | VNZM |  |  |  |  |  |  |  |  |  |  |  |  |  |  |  |  |  |  |  |  |  |  |  |  |  |  |  |  |  |  |  |
| XV301321 |  | CA13 Catalyst Bldg - Insulation Equipment |  | 100d | 2012-04-21 | 2012-08-18 | XV300C00 SS, XE801321 SS+20d |  |  |  | -1d | 0d |  |  | Equipment insulation [150 sqm]; Equipment insulation [1875 h] | 266.07 |  | 1875,00 | 2012-03-30 | E-13-03 | XV301321 | 1875 | 0 | 934 | 13 | 200 | 200 | C | LND | X | V | XV30 | 1321 | V | 13 | X | INS | LND | 1321 | VNZM |  |  |  |  |  |  |  |  |  |  |  |  |  |  |  |  |  |  |  |  |  |  |  |  |  |  |  |  |  |  |  |
|  | 22 | **CA13 - Teal Building Line 2** |  |  | 2010-09-17 | 2012-11-16 |  |  |  |  |  |  |  |  |  |  |  |  |  |  |  |  |  |  |  |  |  |  |  |  |  |  |  |  |  |  |  |  |  |  |  |  |  |  |  |  |  |  |  |  |  |  |  |  |  |  |  |  |  |  |  |  |  |  |  |  |  |  |  |  |  |
|  | C | **Civil Work** |  |  | 2010-09-17 | 2012-05-15 |  |  |  |  |  |  |  |  |  |  |  |  |  |  |  |  |  |  |  |  |  |  |  |  |  |  |  |  |  |  |  |  |  |  |  |  |  |  |  |  |  |  |  |  |  |  |  |  |  |  |  |  |  |  |  |  |  |  |  |  |  |  |  |  |  |
| XC20132205 |  | CA13 Teal Bldg SK1302 - Concrete Works Building Fdtn |  | 243d | 2010-09-17 A | 2011-07-21 A | P3C02D2 (other project) FS+15d, XC201300 FS+10d, XC151300, EC48132203 (other project) FS+10d | 100% | 2010-09-17 | 2011-09-05 |  |  |  | TB26 - V - Construct-Winter partly * | Concrete works [60 cbm]; Concrete works [1800 h] | 72,000 | 25,200 | 1800,00 |  |  | XC20132205 | 1800 | 644 | 934 | 13 | 200 | 200 | C | MO03 | X | C | XC20 | 1322 | C | 13 | X | OB | LND | 1322 | MO11 | x | UDF_G4 |  |  |  |  |  |  |  |  |  |  |  |  |  |  |  |  |  |  |  |  |  |  |  |  |  |  |  |  |  |
| XC401322 |  | CA13 Teal Bldg SK1302 - Concrete Works Building |  | 250d | 2010-11-03 A | 2011-08-22 A | P3C02D2 (other project), XC20132205 SS+20d, IMS-C-000110 FF, EC48132205 (other project) FS+15d, XC401321 SS+5d | 100% | 2010-11-03 | 2011-09-05 |  |  |  |  | Concrete works [140 cbm]; Concrete works [4200 h] | 5,912.7 |  | 4200,00 |  |  | XC401322 | 4200 | 1500 | 934 | 13 | 200 | 200 | C | MO04 | X | C | XC40 | 1322 | C | 13 | X | OB | LND | 1322 | MO11 | x | UDF_G4 | SK1302 | 27.8. | x | x |  |  |  |  |  |  |  |  |  |  |  |  |  |  |  |  |  |  |  |  |  |  |  |  |  |
| XC201322 |  | CA13 Teal Bldg SK1302 - Concrete Works EqptFdtn |  | 20d | 2011-08-20 A | 2011-08-26 A | IMS-C-000060 FF, EC701322 (other project) FF, XC401322 FF+5d, EC45132205 (other project), EC45132215 (other project), EC281322 (other project) FS+20d | 100% | 2011-09-05 | 2011-09-27 |  |  |  |  | Concrete works [50 cbm]; Concrete works [1500 h] | 923.86 |  | 1500,00 |  |  | XC201322 | 1500 | 0 | 934 | 13 | 200 | 200 | C | MO04 | X | C | XC20 | 1322 | C | 13 | X | mis | LND | 1322 | MO11 |  |  |  | 27.8. |  |  |  |  |  |  |  |  |  |  |  |  |  |  |  |  |  |  |  |  |  |  |  |  |  |  |  |
| XC40132210 |  | CA13 Teal Bldg SK1302 - Concrete Works Building finished | milestone | 0d | 2011-08-22 A | 2011-08-22 A | IMS-C-000110 FF, XC401322 FF | 100% | 2011-08-27 | 2011-08-27 |  |  |  |  |  |  |  |  |  |  | XC40132210 | 0 | 0 | 934 | 13 | 200 | 200 | C | MO04 | X | C | XC40 | 1322 | C | 11 | X | OB | LND | 1110 | MO11 |  |  |  |  |  |  | 2011-06-15 | 2011-06-15 | D |  |  |  |  |  |  |  |  |  |  |  |  |  |  |  |  |  |  |  |  |  |  |
| XC501322 |  | CA13 Teal Bldg SK1302 - Finishing Works Rooms |  | 130d | 2011-12-05 | 2012-05-15 | XC510C00 FS+15d, XC401322, EC501322 (other project), XC001322, XC911322 FF+30d, XC40132210 |  |  |  | 76d | 0d |  |  | Finishing Works - Teal Buildings CA12/13 [25025 mhr]; Finishing Works - Teal buildings [25025 h] | 2,502,500 |  | 25025,00 |  |  | XC501322 | 25025 | 0 | 934 | 13 | 200 | 200 | C | CiC | X | C | XC50 | 1322 | C | 13 | X | OB | LND | 1322 |  |  |  | SK1302 |  |  |  |  |  |  | 1 | XC50 |  |  |  |  |  |  |  |  |  |  |  |  |  |  |  |  |  |  |  |  |
| XC501322_1 |  | CA13 Teal Bldg SK1302 - Plastering and Painting (Finishing Works) |  | 20d | 2011-12-05 | 2011-12-27 | XC501322 SS |  |  |  | 76d | 0d |  |  |  |  |  | 25025,00 |  |  | XC501322 | 25025 | 0 | 934 | 13 | 200 | 200 | C | CiC | X | C | XC50 | 1322 | C | 13 | X | OB | LND | 1322 |  |  |  | SK1302 |  |  |  |  |  |  | 1 |  |  |  |  |  |  |  |  |  |  |  |  |  |  |  |  |  |  |  |  |  |
|  | N | **Structural Steel** |  |  | 2011-02-08 | 2011-12-03 |  |  |  |  |  |  |  |  |  |  |  |  |  |  |  |  |  |  |  |  |  |  |  |  |  |  |  |  |  |  |  |  |  |  |  |  |  |  |  |  |  |  |  |  |  |  |  |  |  |  |  |  |  |  |  |  |  |  |  |  |  |  |  |  |  |
| XN701302 |  | CA13 Teal Bldg SK1302 - KMD Assy Drawings | milestone | 0d | 2011-02-08 A | 2011-02-08 A |  | 100% |  |  |  |  | finish on 2011-02-08 | TB26 - V - Construct-Winter partly * |  |  |  | 22t |  |  | XN701302 | 0 | 0 | 934 | 13 | 200 | 200 | C | LND | X | N | XN05 | 1322 | N | 13 | X | SS | LND | 1322 |  |  |  |  |  |  |  |  |  | KMD |  |  | x | XNK |  |  |  |  |  |  |  |  |  |  |  |  |  |  |  |  |  |  |
| XN711302 |  | CA13 Teal Bldg SK1302 - Steel Deliveries | milestone | 0d | 2011-08-02 A | 2011-08-02 A |  | 100% |  |  |  |  | finish on 2011-08-01 | TB26 - 3 - Construction Normal 7days * CA17 |  |  |  | 22t |  |  | XN711302 | 0 | 0 | 934 | 13 | 200 | 200 | C | LND | X | N | XN06 | 1322 | N | 13 | X | SS | LND | 1322 |  |  |  |  | 27.8. |  |  |  |  | SD |  |  |  | XNK |  |  |  |  |  |  |  |  |  |  |  |  |  |  |  |  |  |  |
| XN301322 |  | CA13 Teal Bldg SK1302 - Install Prim Steel / Eqpt Platforms |  | 10d | 2011-10-24 | 2011-11-03 | MI-22106 A/B, XN711302 FS+10d, XC401322, XN701302, P3N02QN (other project) |  |  |  | 0d |  | start on 2011-10-24 |  | Piperacks, Main Structures [11 t]; Piperacks, Main structures [467.5 h] | 18,700 |  | 467,50 |  |  | XN301322 | 467,5 | 0 | 934 | 13 | 200 | 200 | C | LND | X | N | XN30 | 1322 | N | 13 | X | SS | LND | 1322 | ChSK |  |  | SK1302 |  |  |  |  |  |  |  |  |  | XNK | t | 2DC8460 |  |  |  |  |  |  |  |  |  |  |  |  |  |  |  |  |
| XN401322 |  | CA13 Teal Bldg SK1302 - Install Railings,Ladders,etc. |  | 10d | 2011-11-05 | 2011-11-16 | XN301322 FF+10d |  |  |  | 4d | 0d |  |  | Ladders & platforms [1 t]; Ladders & platforms [100 h] | 4,000 |  | 100,00 |  |  | XN401322 | 100 | 0 | 934 | 13 | 200 | 200 | C | LND | X | N | XN40 | 1322 | N | 13 | X | SS | LND | 1322 | ChSK |  |  |  |  |  |  |  |  |  |  |  |  | XNK |  |  |  |  |  |  |  |  |  |  |  |  |  |  |  |  |  |  |
| XN601322 |  | CA13 Teal Bldg SK1302 - Install Gratings |  | 10d | 2011-11-05 | 2011-11-16 | MI-22106 A/B, XN401322 FF |  |  |  | 4d | 0d |  |  | Grating [20 sqm]; Grating [75 h] | 3,000 |  | 75,00 |  |  | XN601322 | 75 | 0 | 934 | 13 | 200 | 200 | C | LND | X | N | XN60 | 1322 | N | 13 | X | SS | LND | 1322 | ChSK |  |  |  |  |  |  |  |  |  |  |  |  | XNK |  |  |  |  |  |  |  |  |  |  |  |  |  |  |  |  |  |  |
| XN801322 |  | CA13 Teal Bldg SK1302 - Cladding Works Walls/Roof |  | 25d | 2011-11-05 | 2011-12-03 | XN301322 |  |  |  | 39d | 0d |  |  | Cladding [300 sqm]; Cladding [1500 h] | 60,000 |  | 1500,00 |  |  | XN801322 | 1500 | 0 | 934 | 13 | 200 | 200 | C | LND | X | N | XN80 | 1322 | N | 13 | X | SS | LND | 1322 | ChSK |  |  |  |  |  |  |  |  | D |  |  |  | XNK |  |  |  |  |  |  |  |  |  |  |  |  |  |  |  |  |  |  |
|  | H | **HVAC** |  |  | 2011-12-28 | 2012-05-26 |  |  |  |  |  |  |  |  |  |  |  |  |  |  |  |  |  |  |  |  |  |  |  |  |  |  |  |  |  |  |  |  |  |  |  |  |  |  |  |  |  |  |  |  |  |  |  |  |  |  |  |  |  |  |  |  |  |  |  |  |  |  |  |  |  |
| XH00132205 |  | CA13 Teal Bldg - Installation HVAC |  | 60d | 2011-12-28 | 2012-03-15 | XC501322 SS+20d, P3H01SG (other project), XC401322, XH000000 FF, EH30132205 (other project), XC501322_1 |  |  |  | 76d | 0d |  |  | HVAC - Teal Buildings CA12/13 [7475 mhr]; HVAC - Teal buildings [7475 h] |  |  | 7475,00 | 2011-05-10 |  | XH00132205 | 7475 | 0 | 934 | 13 | 200 | 200 | C | LND | X | H | XH00 | 1322 | H | 13 | X | hvac | LND | 1322 | ARMO |  |  | SK1302 |  |  |  |  |  |  |  | REL XC50 |  |  |  |  | x | 2011-02-28 | 2011-04-22 | 2011-06-24 |  |  |  |  |  |  |  |  |  |  |  |  |
| XH00132210 |  | CA13 Teal Bldg - Testing/Commissioning HVAC (Start w. temp. Power) |  | 60d | 2012-03-16 | 2012-05-26 | XH000C10, XH00132205, X0300008 FS+20d, X0300080 |  |  |  | 76d | 0d |  |  |  |  |  |  |  |  | XH00132210 | 0 | 0 | 934 | 13 | 200 | 200 | C | LND | X | H | XH20 | 1322 | H | 13 | X | hvac | LND | 1322 | ARMO |  |  | SK1302 |  |  |  |  |  |  |  |  |  |  |  |  |  |  | 2011-07-13 | 2011-09-08 |  |  |  |  |  |  |  |  |  |  |  |  |
| XH00132207 |  | CA13 Teal Bldg - HVAC ready for Heating | milestone | 0d | 2012-03-28 | 2012-03-28 | XH00132210 SS+10d |  |  |  | 310.5d | 126.5d |  |  |  |  |  | 3047 |  |  | XH00132207 | 0 | 0 | 934 | 13 | 200 | 200 | C | LND | X | H | XH00 | 1322 | H | 13 | X | hvac | LND | 1322 | ARMO |  |  | SK1302 |  |  |  |  |  |  |  |  |  |  |  |  |  |  | 2011-07-25 | 2011-07-25 |  |  |  |  |  |  |  |  |  |  |  |  |
|  | U | **Package Units** |  |  |  |  |  |  |  |  |  |  |  |  |  |  |  |  |  |  |  |  |  |  |  |  |  |  |  |  |  |  |  |  |  |  |  |  |  |  |  |  |  |  |  |  |  |  |  |  |  |  |  |  |  |  |  |  |  |  |  |  |  |  |  |  |  |  |  |  |  |
|  | B | **Mechanical - Stationary Equipment** |  |  | 2011-09-01 | 2011-11-19 |  |  |  |  |  |  |  |  |  |  |  |  |  |  |  |  |  |  |  |  |  |  |  |  |  |  |  |  |  |  |  |  |  |  |  |  |  |  |  |  |  |  |  |  |  |  |  |  |  |  |  |  |  |  |  |  |  |  |  |  |  |  |  |  |  |
| XB001322 |  | CA13 Teal Bldg - Install Static Eqpt | level of effort | 68d | 2011-09-01 | 2011-11-19 |  |  |  |  | 21d | 0d |  |  |  |  |  | 3 | 2011-05-20 | E-08-01-10 | XB001322 | 0 | 0 | 934 | 13 | 200 | 200 | C | LND | X | B | XB00 | 1322 | B | 13 | X | EQ | LND | 1322 | VNZM |  |  |  |  |  |  |  |  |  |  |  |  | XBB |  |  |  | 2011-03-10 |  |  | SK1322 |  |  |  |  |  |  |  |  |  |  |  |
| MI-22107 A/B |  | UNLOADING ARMA |  | 13d | 2011-11-05 | 2011-11-19 | XN301322, XB001322 FF, MI-22106 A/B, XB001322 SS, P3A11S2 (other project) |  |  |  | 21d | 7d |  |  | Static Equipment < 10 tons [1 t]; Static equipment < 10t [100 h] | 4,000 |  | 100,00 |  |  | MI-22107 A/B | 100 | 0 |  | 13 |  |  |  |  | X | B |  | 1322 |  |  |  |  |  |  | VNZM |  |  |  |  |  |  |  |  | EQ |  |  |  |  |  |  |  |  |  |  | SK1322 | 1 | 500 | elev +3.00 | 2 KB 4420 | MI-22107 A/B | 2010-09-30 | 2010-11-30 | 2010-12-15 | 2011-01-10 | A11 UNLOADING ARMS (MI-21-/22107/8A/B) | SVT |
| MI-22108 A/B |  | UNLOADING ARMA |  | 13d | 2011-11-05 | 2011-11-19 | P3A11S2 (other project), XN301322, MI-22106 A/B, XB001322 FF, XB001322 SS |  |  |  | 21d | 7d |  |  | Static Equipment < 10 tons [1 t]; Static equipment < 10t [100 h] | 4,000 |  | 100,00 |  |  | MI-22108 A/B | 100 | 0 |  | 13 |  |  |  |  | X | B |  | 1322 |  |  |  |  |  |  | VNZM |  |  |  |  |  |  |  |  | EQ |  |  |  |  |  |  |  |  |  |  | SK1322 | 1 | 500 | elev +3.00 | 2 KB 4420 | MI-22108 A/B | 2010-09-30 | 2010-11-30 | 2010-12-15 | 2011-01-10 | A11 UNLOADING ARMS (MI-21-/22107/8A/B) | SVT |

Notes:
- XC401322: Current Status: 110303 (WL) Resume Date 09.05.11 nach Vorgabe H. Bucher / 19.02.2011 (O.Siegel): laut Terminplan vom MO11 vom 16-Feb-11 werden die / Arbeiten am 01-Mrz-11 wierderaufgenommen. Das Enddatum wurde mit / 09-Jun-11 datiert.
- XC40132210: P3 Activity Log Info: excl. openings for Compressor Lifts
- XC501322: Current Status: 13-01-11 - Volkmann - analog CA 12
- XC501322_1: Current Status: 13-01-11 - Volkmann - analog CA 12
- XN711302: Scope: 09.02.2011: weight: 6 ton - Jan 4 ton ; Feb 2 ton
- XH00132210: Current Status: 21.01.2011 - Siegel - Vorgдnger zur IBN HVAC / Condensat, LP-Dampf, Kьhlwasser von FF + 30 Tage Lag auf FS + 0 geдndert!
- XB001322: Current Status: 110304 (WL) Add PRED XN201222 Install Prim Steel / Eqpt Platforms / 110304 (WL) Delete PRED XH00122205 Installation HVAC

| ID | WBS | Activity | Type | Duration | Start | Finish | Predecessors | Complete | Remaining | Planned start | Planned finish | Total float | Free float | Calendar | Resources | Cost | Actual cost | TB26 Ressource Budget | UDF_Weight (ton) | WEIGHT | UDF_LEVEL | UDF_TAG No | UDF_Object No | UDF_PACKAGE | UDF_SAVE ACT ID | UDF_BUDGETED LABOR UNIT | UDF_ACTUAL LABOR UNIT | Constr. Area | Zeigen/n. Zeigen | WBS Phase | WBS Discipline | WBS Objects | Subcontractor | UDF_CONTRACT START DATE | UDF_CONTRACT FINISH DATE | UDF_CONTRACT ITEM | Department | PMT-Respons. | WBS Type of Work | Russia WBS Discipline (Russia) | Russia Construction Area | Russia WBS Phase | IMS | UPT | Russia WBS Objects | UDF_CONTRACT INDICATOR | UDF_SELECT UPDATE PROGRESS | UDF_CHECK RESOURCE DATES | PMT-Area | PMT-Schedule Org | PMT-Phase | UDF_PLANNED START | UDF_PLANNED FINISH | UDF_CONTRACT FINISH DATE REV1 | UDF_CONTRACT START DATE REV1 | TB26 Semantics | TB26 Material Res Values | UDF_ELECTRICAL START | UDF_ELECTRICAL FINISH | UDF_CHECK BASELINE | UDF_COMMENTS_0827 | Filter | UDF_Vendor Representatives | geplanter Start | geplantes Ende | UDF_PENALIZED FINISH |
| --- | --- | --- | --- | --- | --- | --- | --- | --- | --- | --- | --- | --- | --- | --- | --- | --- | --- | --- | --- | --- | --- | --- | --- | --- | --- | --- | --- | --- | --- | --- | --- | --- | --- | --- | --- | --- | --- | --- | --- | --- | --- | --- | --- | --- | --- | --- | --- | --- | --- | --- | --- | --- | --- | --- | --- | --- | --- | --- | --- | --- | --- | --- | --- | --- | --- | --- |
|  | M | **Mechanical - Rotating Equipment** |  |  | 2011-11-05 | 2011-11-28 |  |  |  |  |  |  |  |  |  |  |  |  |  |  |  |  |  |  |  |  |  |  |  |  |  |  |  |  |  |  |  |  |  |  |  |  |  |  |  |  |  |  |  |  |  |  |  |  |  |  |  |  |  |  |  |  |  |  |  |  |
| P-22102 A/B |  | FEED AND CATALYST WASTE PUMPS |  | 20d | 2011-11-05 | 2011-11-28 | P3M08S2B (other project) FF+20d, XM001322 SS, XN301322, XM001322 FF |  |  |  |  | 4d | 0d |  | Rotating Equipment (w/ lube oil unit) [0.08 t]; Rotating equipment (w/ lube oil unit) [7 h] | 320 |  | 7,00 | 0,08 | 435 | steel foundation +0.00 | P-22102 A/B | SK1322 | M08 TEAL/DONOR FEED AND CATALYST WASTE PUMPS | P-22102 A/B | 7 | 0 | 13 | EQ | X | M | 1322 | VNZM |  |  |  |  |  |  |  |  |  |  |  |  |  |  |  |  |  |  |  |  |  |  |  |  |  |  |  |  |  |  |  |  |  |
| XM001322 |  | CA13 Teal Bldg - Install Rotating Eqpt | level of effort | 20d | 2011-11-05 | 2011-11-28 |  |  |  |  |  | 4d | 0d |  |  |  |  | 1 |  |  |  |  |  |  | XM001322 | 0 | 0 | 13 |  | X | M | 1322 | VNZM | 2011-03-10 | 2011-05-20 | E-08-01-10 | 934 | LND | XM00 | M | 13 | X | EQ | LND | 1322 |  |  |  |  |  |  |  |  |  |  |  |  |  |  |  |  |  |  |  |  |  |
|  | R | **Piping** |  |  | 2011-07-20 | 2012-04-02 |  |  |  |  |  |  |  |  |  |  |  |  |  |  |  |  |  |  |  |  |  |  |  |  |  |  |  |  |  |  |  |  |  |  |  |  |  |  |  |  |  |  |  |  |  |  |  |  |  |  |  |  |  |  |  |  |  |  |  |  |
| XR201322 |  | CA13 Teal Bldg SK1302 - Piping Prefabrication |  | 104d | 2011-07-20 A | 2011-11-18 | ER491322 (other project) SS+18d |  | 71d |  |  | 22d | 18d |  | A/G piping prefabrication [410 Fpi]; A/G Piping (Prefab) [1537.5 h] | 1,419.05 |  | 1537,50 |  |  |  |  |  |  | XR201322 | 1537,5 | 0 | 13 |  | X | R | 1322 | VNZM |  |  |  | 934 | LND | XR20 | R | 13 | X | PRP | LND | 1322 | UDF_G4 | 27.8. | x | 200 | 200 | C |  |  |  |  |  |  |  |  |  |  |  |  |  |  |  |
| XR401322 |  | CA13 Teal Bldg SK1302 - Piping Installation |  | 70d | 2011-11-17 | 2012-02-13 | XN301322, P-22102 A/B FS-10d, XR201322 FS-20d, P3J02DS (other project), MI-22107 A/B FS-20d, IMS-C-000190 FF, MI-22108 A/B FS-20d, P3J02S (other project) FF+20d, P3J04IS (other project) FF+20d, MI-22106 A/B FS-20d, XN601322, P3J01AS (other project), P3J04CS1 (other project), P3J02AS (other project) |  |  |  |  | 4d | 0d |  | A/G piping field installation [500 Fpi]; Control & Shut-off valves [26 pcs]; A/G Piping (Field) [3125 h]; Install Control & Shut-off Valves [136.5 h] | 10,500.58 |  | 3261,50 |  |  |  |  |  |  | XR401322 | 3261,5 | 0 | 13 |  | X | R | 1322 | VNZM | 2011-01-20 |  | E-06-03-04 | 934 | LND | XR40 | R | 13 | X | PI | LND | 1322 |  |  |  | 200 | 200 | C | 2011-03-30 |  |  |  |  |  |  |  |  |  |  |  |  |  |  |
| XR601322 |  | CA13 Teal Bldg SK1302 - Piping Pressure Tests |  | 30d | 2012-02-14 | 2012-03-21 | XR401322 FF+12d, XR605103 FF+20d |  |  |  |  | 14d | 0d |  |  |  |  | 113 |  |  |  |  |  |  | XR601322 | 0 | 0 | 13 |  | X | R | 1322 | VNZM |  |  | E-06-03-04 | 934 | LND | XR60 | R | 13 | X | HY | LND | 1322 |  |  |  | 200 | 200 | C |  |  |  |  |  |  |  |  |  |  |  |  |  |  |  |
| XR801322 |  | CA13 Teal Bldg SK1302 - Piping Reinstatement |  | 20d | 2012-03-10 | 2012-04-02 | XR601322 FF+10d, IMS-C-000360 FF |  |  |  |  | 14d | 0d |  |  |  |  | 56 |  |  |  |  |  |  | XR801322 | 0 | 0 | 13 |  | X | R | 1322 | VNZM |  | 2011-11-30 | E-06-03-04 | 934 | LND | XR80 | R | 13 | X | PI | LND | 1322 |  |  |  | 200 | 200 | C |  | 2012-02-11 |  |  |  |  |  |  |  |  |  |  |  |  |  |
|  | E | **Electrical** |  |  | 2011-04-18 | 2012-08-15 |  |  |  |  |  |  |  |  |  |  |  |  |  |  |  |  |  |  |  |  |  |  |  |  |  |  |  |  |  |  |  |  |  |  |  |  |  |  |  |  |  |  |  |  |  |  |  |  |  |  |  |  |  |  |  |  |  |  |  |  |
| XC911322 |  | CA13 Teal Bldg - Install Earthing&Lightn.Sys_CIVIL |  | 118d | 2011-04-18 A | 2011-08-27 A | XC401322 FF, EE901322 (other project) | 100% |  | 2011-04-18 | 2011-09-05 |  |  | TB26 - V - Construct-Winter partly * | Grounding & Lightning [50 pcs]; Grounding & Lightning [562.5 h] | 22,500 | 22,500 | 562,50 |  |  |  |  |  |  | XC911322 | 562,5 | 450 | 13 |  | X | C | 1322 | MO11 | 2011-05-10 | 2011-11-30 | E-16-07-05 | 934 | LND | XE91 | C | 13 | X | EA | LND | 1322 | UDF_G4 | 27.8. | x | 200 | 200 | C |  |  |  |  |  |  |  |  |  |  |  |  |  |  |  |
| XE911325 |  | CA13 Teal Bldg - Install Earthing&Lightn.Sys_E/I |  | 20d | 2011-11-29 | 2012-01-18 | XN301322, MI-22106 A/B, MI-22107 A/B, MI-22108 A/B, P-22102 A/B |  |  |  |  | 114d | 201d | TB26 - V - Construct-Winter partly * |  |  |  | 55 |  |  |  |  |  |  | XE911325 | 0 | 0 | 13 |  | X | E | 1322 | URMA | 2011-05-10 | 2011-11-30 | E-16-07-05 | 934 | LND | XE91 | E | 13 | X | EA | LND | 1322 | UDF_G3 |  |  | 200 | 200 | C |  |  | 2012-04-15 | 2011-07-25 |  |  |  |  |  |  |  |  |  |  |  |
| XE401322 |  | CA13 Teal Bldg - Install Cable Trays |  | 30d | 2011-12-28 | 2012-02-07 | XN801322, XR401322 SS+35d, EE46132210 (other project), XN601322 |  |  |  |  | 19d | 0d |  | Cable trays/conduits [180 m]; Cable trays [540 h] | 21,600 |  | 540,00 |  |  |  |  |  |  | XE401322 | 540 | 0 | 13 |  | X | E | 1322 | URMA | 2011-05-10 | 2011-08-20 | E-15-01-09 | 934 | LND | XE40 | E | 13 | X | EL | LND | 1322 | UDF_G3 |  |  | 200 | 200 | C |  |  | 2011-12-20 | 2011-07-20 | m | 300 | 2011-08-04 | 2011-09-19 | x | to be checked |  |  |  |  |  |
| XE701322 |  | CA13 Teal Bldg - Install Lighting & Small Power |  | 60d | 2012-01-27 | 2012-04-07 | XP341610 FS+50d, EE761322 (other project), P3E09S (other project), XC401322, XE401322 SS+20d |  |  |  |  | 69d | 30d |  | Cable Pulling [500 m]; Lighting illuminates [50 pcs]; Cable pulling [250 h]; Lighting (iluminates) [500 h] | 30,000 |  | 750,00 |  |  |  |  |  |  | XE701322 | 750 | 0 | 13 |  | X | E | 1322 | URMA | 2011-05-10 | 2012-01-31 | E-16-03-01 | 934 | LND | XE70 | E | 13 | X | EL | LND | 1322 |  |  |  | 200 | 200 | C |  |  | 2012-05-10 | 2011-08-15 |  |  |  |  |  |  | x |  |  |  |  |
| XE341322 |  | CA13 Teal Bldg -Install Local Operation Panels |  | 20d | 2012-02-08 | 2012-03-02 | XE401322, EE46132210 (other project), XR401322 SS+35d, MI-22106 A/B, MI-22107 A/B, MI-22108 A/B, P-22102 A/B |  |  |  |  | 46d | 117.5d |  | Field Panels [3 pcs]; Field panels [60 h] | 2,400 |  | 60,00 |  |  |  |  |  |  | XE341322 | 60 | 0 | 13 |  | X | E | 1322 | URMA | 2011-05-10 | 2011-11-30 | E-16-07-05 | 934 | LND | XE34 | E | 13 | X | EL | LND | 1322 | UDF_G3 |  |  | 200 | 200 | C |  |  | 2012-04-15 | 2011-07-25 |  |  |  |  |  | to be checked |  |  |  |  |  |
| XE801322 |  | CA13 Teal Bldg - Install Heat Tracing |  | 30d | 2012-02-27 | 2012-04-02 | E3E1950 (other project), XW501322 FF+20d, P3E19S (other project), P-22102 A/B, XR401322, XE800C00 SS, XR601322 FF+10d |  |  |  |  | 45d | 0d |  | Electrical Heat Tracing [800 m]; Electrical heat tracing [400 h] | 16,000 |  | 400,00 |  |  |  |  |  |  | XE801322 | 400 | 0 | 13 |  | X | E | 1322 | URMA | 2011-06-20 | 2012-03-20 | E-16-04-01 | 934 | LND | XE80 | E | 13 | X | HT | LND | 1322 | UDF_G3 |  |  | 200 | 200 | C |  |  | 2012-06-30 | 2011-09-15 |  |  |  |  |  | to be installed later |  | 005 |  |  |  |
| XE921322 |  | CA13 Teal Bldg - Install Fire Detection System |  | 60d | 2012-05-16 | 2012-07-25 | XJ421322, XC501322, XH00132205, XE701322 |  |  |  |  | 210.5d | 0d |  | Fire Detection System; Fire detection system |  |  | 0,00 |  |  |  |  |  |  | XE921322 | 0 | 0 | 13 |  | X | E | 1322 |  | 2011-05-10 | 2011-11-30 | E-16-07-05 | 934 | UIO | XE92 | E | 13 | X | FGDS | LND | 1322 |  |  |  | 200 | 200 | C |  |  |  |  |  |  |  |  | x |  | x |  | 2012-02-17 | 2012-07-13 |  |
| XE961322 |  | CA13 Teal Bldg - Install Communication System |  | 60d | 2012-05-16 | 2012-07-25 | XE701322, XJ421322, XH00132205, XE921322 SS, XC501322, E3E1350 (other project) |  |  |  |  | 211.5d |  | TB26 - V - Construct-Winter partly * | Communication System |  |  | 0,00 |  |  |  |  |  |  | XE961322 | 0 | 0 | 13 |  | X | E | 1322 |  | 2011-05-10 | 2011-11-30 | E-16-07-05 | 934 | LND | XE96 | E | 13 | X | CS | LND | 1322 |  |  |  | 200 | 200 | C |  |  |  |  |  |  |  |  | x |  | x |  | 2012-02-17 | 2012-07-13 |  |
| XE501322 |  | CA13 Teal Bldg - Cable Pulling Electric |  | 30d | 2012-06-18 | 2012-07-23 | P3E15CS (other project), EE561322 (other project), XE501304 SS, P3E15BS (other project), XE401322, P3E15AS (other project), XE500C01, XE501301 SS, XE505103 SS+10d, XE505104 SS+10d, XE505401 SS+12d |  |  |  |  | -71.5d | 0d | TB26 - V - Construct-Winter partly * | Cable Pulling [2200 m]; Cable pulling [1100 h] | 44,000 |  | 1100,00 |  |  |  |  |  |  | XE501322 | 1100 | 0 | 13 |  | X | E | 1322 | URMA | 2011-05-20 | 2012-02-10 | E-16-01-01 | 934 | LND | XE50 | E | 13 | X | EL | LND | 1322 | UDF_G3 |  |  | 200 | 200 | C |  |  | 2012-07-01 | 2011-10-01 | m | 2300 | 2011-09-20 | 2012-03-09 |  |  |  |  |  |  |  |
| XE601322 |  | CA13 Teal Bldg - Cable Termination & Testing |  | 50d | 2012-06-18 | 2012-08-15 | XE501322 FF+20d, MI-22106 A/B, MI-22107 A/B, MI-22108 A/B, P-22102 A/B, XE341322 FF+20d |  |  |  |  | -71.5d | 9d | TB26 - V - Construct-Winter partly * | Cable connecting [20 pcs]; Cable connecting [50 h] | 2,000 |  | 50,00 |  |  |  |  |  |  | XE601322 | 50 | 0 | 13 |  | X | E | 1322 | URMA | 2011-04-20 | 2011-11-30 | E-16-02-01 | 934 | LND | XE60 | E | 13 | X | ET | LND | 1322 | UDF_G3 |  |  | 200 | 200 | C |  |  | 2012-08-14 | 2011-12-10 |  |  |  |  |  |  |  |  |  |  |  |
|  | J | **Instrumentation** |  |  | 2011-12-28 | 2012-11-16 |  |  |  |  |  |  |  |  |  |  |  |  |  |  |  |  |  |  |  |  |  |  |  |  |  |  |  |  |  |  |  |  |  |  |  |  |  |  |  |  |  |  |  |  |  |  |  |  |  |  |  |  |  |  |  |  |  |  |  |  |
| XJ321322 |  | CA13 Teal Bldg - Install Junction Boxes |  | 30d | 2011-12-28 | 2012-02-07 | P3J06ES (other project) FS+14d, MI-22108 A/B FF+10d, EJ321322 (other project), MI-22107 A/B FF+10d, MI-22106 A/B FF+10d, P3J06FS (other project) FF, P-22102 A/B, XR401322 SS+35d |  |  |  |  | 4d | 0d |  | Junction Boxes/Cabinets/Panels [23 pcs]; Install Junction Boxes/ Cabinets/ Panels [575 h] | 23,000 |  | 575,00 |  |  |  |  |  |  | XJ321322 | 575 | 0 | 13 |  | X | J | 1322 | URMA | 2011-05-10 | 2012-03-20 | E-17-04-05 | 934 | LND | XJ32 | J | 13 | X | IN | LND | 1322 | UDF_G3 |  |  | 200 | 200 | C |  |  | 2012-08-15 | 2011-07-25 |  |  |  |  |  | to be installed later |  |  |  |  |  |
| XJ421322 |  | CA13 Teal Bldg - Install Secondary Cable Trays |  | 30d | 2012-01-21 | 2012-02-25 | EJ46132210 (other project), XJ321322 FF+15d, XE401322 FF, XR401322 SS+35d, MI-22106 A/B, MI-22107 A/B, MI-22108 A/B, P-22102 A/B |  |  |  |  | 4d | 0d |  | Secondary cable trays [140 m]; Install secondary cable trays [525 h] | 21,000 |  | 525,00 |  |  |  |  |  |  | XJ421322 | 525 | 0 | 13 |  | X | J | 1322 | URMA | 2011-05-10 | 2011-08-20 | E-15-01-09 | 934 | LND | XJ42 | J | 13 | X | IN | LND | 1322 |  |  |  | 200 | 200 | C |  |  | 2011-12-20 | 2011-07-20 | m | 220 | 2011-08-04 | 2011-09-19 | x | to be installed later | x |  |  |  |  |
| XJ301322 |  | CA13 Teal Bldg - Install Field Instruments |  | 40d | 2012-02-14 | 2012-04-02 | P3J05S (other project), EJ361322 (other project), XR801322 FF, P3J12AS (other project), P3J04AS (other project), P3J04BS (other project), XR401322 SS+20d, MI-22106 A/B, MI-22107 A/B, MI-22108 A/B, P-22102 A/B |  |  |  |  | 14d | 0d |  | Field Instruments [140 pcs]; Install field instruments [770 h] | 30,800 |  | 770,00 |  |  |  |  |  |  | XJ301322 | 770 | 0 | 13 |  | X | J | 1322 | URMA | 2011-05-10 | 2012-03-20 | E-17-04-05 | 934 | LND | XJ30 | J | 13 | X | IN | LND | 1322 | UDF_G3 |  |  | 200 | 200 | C |  |  | 2012-08-15 | 2011-07-25 |  |  |  |  |  | to be installed later |  |  |  |  |  |
| XJ441322 |  | CA13 Teal Bldg - Install Conduits to Instrm |  | 40d | 2012-02-27 | 2012-04-13 | XJ321322, MI-22106 A/B, MI-22107 A/B, MI-22108 A/B, P-22102 A/B, XR401322 SS+35d, XE401322, XJ421322 |  |  |  |  | 4d | 0d |  |  |  |  |  |  |  |  |  |  |  | XJ441322 | 0 | 0 | 13 |  | X | J | 1322 | URMA | 2011-05-10 | 2012-03-20 | E-17-04-05 | 934 | LND | XJ44 | J | 13 | X | IN | LND | 1322 |  |  |  | 200 | 200 | C |  |  | 2012-08-15 | 2011-07-25 |  |  |  |  |  | to be installed later |  |  |  |  |  |
| XJ541322 |  | CA13 Teal Bldg - Pulling Singlecore Cables |  | 40d | 2012-03-12 | 2012-04-30 | XE500C01, XJ301322 FF+20d, EJ801322 (other project), XJ441322 SS+10d, XJ421322 |  |  |  |  | 35d | 31d | TB26 - V - Construct-Winter partly * | Singlecore cables [12000 m]; Pull singlecore cables [9000 h] | 360,000 |  | 9000,00 |  |  |  |  |  |  | XJ541322 | 9000 | 0 | 13 |  | X | J | 1322 | URMA | 2011-05-10 | 2012-03-20 | E-17-04-05 | 934 | LND | XJ54 | J | 13 | X | IN | LND | 1322 |  |  |  | 200 | 200 | C |  |  | 2012-08-15 | 2011-07-25 | m | 11900 | 2011-11-18 | 2011-12-22 |  |  |  |  |  |  |  |
| XJ701322 |  | CA13 Teal Bldg - Instrument Tubing |  | 20d | 2012-04-03 | 2012-04-25 | XJ301322 FF+20d, XR401322 |  |  |  |  | 14d | 10d |  |  |  |  |  |  |  |  |  |  |  | XJ701322 | 0 | 0 | 13 |  | X | J | 1322 | URMA | 2011-05-10 | 2012-03-20 | E-17-04-05 | 934 | LND | XJ70 | J | 13 | X | IN | LND | 1322 |  |  |  | 200 | 200 | C |  |  | 2012-08-15 | 2011-07-25 |  |  |  |  |  |  |  |  |  |  |  |
| XJ391322 |  | CA13 Teal Bldg - Install Earthing Field Eqpt |  | 20d | 2012-04-14 | 2012-05-08 | XJ321322 FF+20d, XJ301322 FF+17d, XJ421322, XJ441322 |  |  |  |  | 4d | 0d |  |  |  |  |  |  |  |  |  |  |  | XJ391322 | 0 | 0 | 13 |  | X | J | 1322 | URMA | 2011-05-10 | 2012-03-20 | E-17-04-05 | 934 | LND | XJ39 | J | 13 | X | IN | LND | 1322 |  |  |  | 200 | 200 | C |  |  | 2012-08-15 | 2011-07-25 |  |  |  |  |  |  |  |  |  |  |  |
| XJ641322 |  | CA13 Teal Bldg - Termin Singlecore Cables |  | 40d | 2012-05-10 | 2012-06-26 | XJ541322 FF+15d, XJ701322, XJ391322, XJ301322, XJ301322 FF |  |  |  |  | 4d | 91d |  | Termination Field [705 mhr]; Termination field [705 h] | 70,500 |  | 705,00 |  |  |  |  |  |  | XJ641322 | 705 | 0 | 13 |  | X | J | 1322 | URMA | 2011-05-10 | 2012-03-20 | E-17-04-05 | 934 | LND | XJ64 | J | 13 | X | IN | LND | 1322 |  |  |  | 200 | 200 | C |  |  | 2012-08-15 | 2011-07-25 |  |  |  |  |  |  |  |  |  |  |  |
| XJ521322 |  | CA13 Teal Bldg - Pulling Multicore Cables |  | 40d | 2012-06-20 | 2012-08-06 | XE500C01, XJ321322 SS+20d, XJ521304 SS+10d, XE401322, XJ525401 SS+18d, XJ525102 SS+15d, XJ525103 SS+12d, XJ525104 SS+10d |  |  |  |  | -23.5d | 0d | TB26 - V - Construct-Winter partly * | Multicore cables [4000 m]; Pull multicore cables [2000 h] | 80,000 |  | 2000,00 |  |  |  |  |  |  | XJ521322 | 2000 | 0 | 13 |  | X | J | 1322 | URMA | 2011-05-20 | 2012-03-10 | E-17-01-01 | 934 | LND | XJ52 | J | 13 | X | IN | LND | 1322 |  |  |  | 200 | 200 | C |  |  | 2012-06-16 | 2011-11-01 | m | 2900 | 2011-09-21 | 2011-11-07 |  | to be checked |  |  |  |  |  |
| XJ621322 |  | CA13 Teal Bldg - Termin Multicore Cables |  | 30d | 2012-07-13 | 2012-08-17 | XJ521322 FF+10d, XJ321322 |  |  |  |  | -23.5d | 57d |  | Termination Field [705 mhr]; Termination field [705 h] | 70,500 |  | 705,00 |  |  |  |  |  |  | XJ621322 | 705 | 0 | 13 |  | X | J | 1322 | URMA | 2011-05-20 | 2012-03-10 | E-17-01-01 | 934 | LND | XJ62 | J | 13 | X | IN | LND | 1322 |  |  |  | 200 | 200 | C |  |  | 2012-06-16 | 2011-11-01 |  |  |  |  |  |  |  |  |  |  |  |
| XJ801322 |  | CA13 Teal Bldg - Inspections/ Mech. Acceptance/ Loop Checks |  | 70d | 2012-08-25 | 2012-11-16 | X030410030, IMS-C-000420 FF, XJ641322 FF+20d, XJ391322 SS+10d, X3J120, XJ701322 SS, EJ801322 (other project), XE601322, XJ621322 FF+20d |  |  |  |  | -80.5d | 15d |  | Loop Checks [350 pcs]; Loop checks [1750 h] | 70,000 |  | 1750,00 |  |  |  |  |  |  | XJ801322 | 1750 | 0 | 13 |  | X | J | 1322 | URMA | 2011-06-10 | 2012-04-30 | E-17-02-01 | 934 | LND | XJ80 | J | 13 | X | LT | LND | 1322 |  |  |  | 200 | 200 | C |  |  | 2012-08-18 | 2012-03-01 |  |  |  |  |  |  |  |  |  |  | 2012-08-18 |

Notes:
- XM001322: Current Status: 110304 (WL) Rotating Equipment P-21102A/B Teal Feed Pump / 110304 (WL) Add PRED XN201222 Install Prim Steel / Eqpt Platforms / 110304 (WL) Delete PRED XH00122205 Installation HVAC
- XR401322: P3 Activity Log Info: Start with Fire Water / System / Current Status: 110304 (WL) Delete PRED XN801222 Cladding Works Walls/Roof
- XE921322: Scope: CA13 Polymerization Line 2 / FDS - 49 external sensors / GDS - 26 external sensors / DS + SAME
- XE961322: Scope: CA13 Polymerization Line 2 / FDS - 49 external sensors / GDS - 26 external sensors / DS + SAME

| ID | WBS | Activity | Type | Duration | Start | Finish | Predecessors | Complete | Remaining | Planned start | Planned finish | Total float | Free float | Calendar | Resources | Cost | Actual cost | TB26 Ressource Budget | UDF_SELECT UPDATE PROGRESS | UDF_SAVE ACT ID | UDF_BUDGETED LABOR UNIT | UDF_ACTUAL LABOR UNIT | UDF_CHECK RESOURCE DATES | Department | Constr. Area | PMT-Area | PMT-Schedule Org | PMT-Phase | PMT-Respons. | WBS Phase | WBS Discipline | WBS Type of Work | WBS Objects | Russia WBS Discipline (Russia) | Russia Construction Area | Russia WBS Phase | IMS | UPT | Russia WBS Objects | Subcontractor | UDF_CONTRACT FINISH DATE | UDF_CONTRACT ITEM | Filter | UDF_Weight (ton) | WEIGHT | UDF_LEVEL | UDF_PO No | UDF_TAG No | UDF_Object No | UDF_DELIVERY DATE PO | UDF_DELIVERY DATE DISPATCH PLANNED | UDF_DELIVERY DATE TO SITE PLANNED | UDF_DELIVERY DATE SITE NEED DATE | UDF_SHIPMENT No | UDF_PACKAGE | UDF_SUPPLIER | Zeigen/n. Zeigen | UDF_CONTRACT START DATE | Type of Work | UDF_CONTRACT INDICATOR | TB26 Semantics | TB26 Material Res Values | UDF_ELECTRICAL START | UDF_ELECTRICAL FINISH | UDF_CONTRACT FINISH DATE REV1 | UDF_CONTRACT START DATE REV1 | UDF_CHECK BASELINE | UDF_COMMENTS_0827 | UDF_Vendor Representatives | 4 week lookahead | UDF_PLANNED START | UDF_PLANNED FINISH |
| --- | --- | --- | --- | --- | --- | --- | --- | --- | --- | --- | --- | --- | --- | --- | --- | --- | --- | --- | --- | --- | --- | --- | --- | --- | --- | --- | --- | --- | --- | --- | --- | --- | --- | --- | --- | --- | --- | --- | --- | --- | --- | --- | --- | --- | --- | --- | --- | --- | --- | --- | --- | --- | --- | --- | --- | --- | --- | --- | --- | --- | --- | --- | --- | --- | --- | --- | --- | --- | --- | --- | --- | --- |
|  | S | **Safety & Environment** |  |  |  |  |  |  |  |  |  |  |  |  |  |  |  |  |  |  |  |  |  |  |  |  |  |  |  |  |  |  |  |  |  |  |  |  |  |  |  |  |  |  |  |  |  |  |  |  |  |  |  |  |  |  |  |  |  |  |  |  |  |  |  |  |  |  |  |  |  |  |
|  | W | **Painting** |  |  | 2011-07-30 | 2011-10-06 |  |  |  |  |  |  |  |  |  |  |  |  |  |  |  |  |  |  |  |  |  |  |  |  |  |  |  |  |  |  |  |  |  |  |  |  |  |  |  |  |  |  |  |  |  |  |  |  |  |  |  |  |  |  |  |  |  |  |  |  |  |  |  |  |  |  |
| XW501322 |  | CA13 Teal Bldg - Surf.Protection Piping |  | 59d | 2011-07-30 A | 2011-10-06 | XR201322 SS |  | 35d |  |  | 169d | 124d |  | Piping painting [142 sqm]; Piping painting [355 h] | 186.25 |  | 355,00 | 27.8. | XW501322 | 355 | 0 | ok | 934 | 13 | 200 | 200 | C | LND | X | W | XW50 | 1322 | W | 13 | X | PA | LND | 1322 | VNZM |  |  |  |  |  |  |  |  |  |  |  |  |  |  |  |  |  |  |  |  |  |  |  |  |  |  |  |  |  |  |  |  |
|  | V | **Insulation** |  |  | 2012-03-22 | 2012-07-05 |  |  |  |  |  |  |  |  |  |  |  |  |  |  |  |  |  |  |  |  |  |  |  |  |  |  |  |  |  |  |  |  |  |  |  |  |  |  |  |  |  |  |  |  |  |  |  |  |  |  |  |  |  |  |  |  |  |  |  |  |  |  |  |  |  |  |
| XV301322 |  | CA13 Teal Bldg - Insulation Equipment |  | 80d | 2012-03-22 | 2012-06-28 | XE801322 SS+20d |  |  |  |  | 43d | 0d | TB26 - V - Construct-Winter partly * | Equipment insulation [75 sqm]; Equipment insulation [938 h] | 133.04 |  | 938,00 |  | XV301322 | 938 | 0 |  | 934 | 13 | 200 | 200 | C | LND | X | V | XV30 | 1322 | V | 13 | X | INS | LND | 1322 | VNZM | 2012-03-30 | E-13-03 |  |  |  |  |  |  |  |  |  |  |  |  |  |  |  |  |  |  |  |  |  |  |  |  |  |  |  |  |  |  |
| XV501322 |  | CA13 Teal Bldg - Insulation Piping |  | 70d | 2012-04-12 | 2012-07-05 | XR601322 SS+10d, XV301322 FF+6d, XE801322 FF+20d |  |  |  |  | 43d | 138.5d | TB26 - T - Construct-Winter-3 (Dec/Jan/Feb free) * | Piping insulation [120 sqm]; Piping insulation [900 h] | 532.14 |  | 900,00 |  | XV501322 | 900 | 0 |  | 934 | 13 | 200 | 200 | C | LND | X | V | XV50 | 1322 | V | 13 | X | INS | LND | 1322 | VNZM | 2012-04-30 | E-13-01 |  |  |  |  |  |  |  |  |  |  |  |  |  |  |  |  |  |  |  |  |  |  |  |  |  |  |  |  |  |  |
|  | 30 | **CA13 - Other Ground Based Eqpt** |  |  | 2010-09-30 | 2012-10-25 |  |  |  |  |  |  |  |  |  |  |  |  |  |  |  |  |  |  |  |  |  |  |  |  |  |  |  |  |  |  |  |  |  |  |  |  |  |  |  |  |  |  |  |  |  |  |  |  |  |  |  |  |  |  |  |  |  |  |  |  |  |  |  |  |  |  |
|  | C | **Civil Work** |  |  | 2012-03-26 | 2012-04-18 |  |  |  |  |  |  |  |  |  |  |  |  |  |  |  |  |  |  |  |  |  |  |  |  |  |  |  |  |  |  |  |  |  |  |  |  |  |  |  |  |  |  |  |  |  |  |  |  |  |  |  |  |  |  |  |  |  |  |  |  |  |  |  |  |  |  |
| XC201330 |  | CA13 OthGrBasedEqpt - Concrete Works Foundation |  | 20d | 2012-03-26 | 2012-04-18 | XC151300, XC20130410 SS+10d, EC281330 (other project) FS+10d, XC201230 SS, IMS-C-000060 FF, XC301300 SS+20d, XC191305 SS+10d |  |  |  |  | -51d | 0d | TB26 - V - Construct-Winter partly * | Concrete works [80 cbm]; Concrete works [3300 h] |  |  | 3300,00 |  | XC201330 | 2400 | 0 |  | 934 | 13 | 200 | 200 | C | MO03 | X | C | XC20 | 1330 | C | 13 | X | mis | LND | 1330 | MO11 |  |  | 1 |  |  |  |  |  |  |  |  |  |  |  |  |  |  |  |  |  |  |  |  |  |  |  |  |  |  |  |  |  |
|  | B | **Mechanical - Stationary Equipment** |  |  |  |  |  |  |  |  |  |  |  |  |  |  |  |  |  |  |  |  |  |  |  |  |  |  |  |  |  |  |  |  |  |  |  |  |  |  |  |  |  |  |  |  |  |  |  |  |  |  |  |  |  |  |  |  |  |  |  |  |  |  |  |  |  |  |  |  |  |  |
|  | M | **Mechanical - Rotating Equipment** |  |  | 2012-04-19 | 2012-04-30 |  |  |  |  |  |  |  |  |  |  |  |  |  |  |  |  |  |  |  |  |  |  |  |  |  |  |  |  |  |  |  |  |  |  |  |  |  |  |  |  |  |  |  |  |  |  |  |  |  |  |  |  |  |  |  |  |  |  |  |  |  |  |  |  |  |  |
| P-22201A/B |  | REACTOR QUENCH LIQUID PUMPS |  | 10d | 2012-04-19 | 2012-04-30 | P3M05S2 (other project), ER291200 (other project), XM001330 SS, XM001330 FF, HO-22206, XN201301l, HO-22205, XC201330, XC911330 |  |  |  |  | -70d | 0d |  | Rotating Equipment (w/ lube oil unit) [12.4 t]; Rotating equipment (w/ lube oil unit) [1013.25 h] | 49,600 |  | 1013,25 |  | P-22201A/B | 1013,25 | 0 |  |  | 13 |  |  |  |  | X | M |  | 1330 |  |  |  |  |  |  | VNZM |  |  |  | 11,58 | 5790 | concrete +0.00 | 2 PA 6550 / 4 | P-22201A/B | SK1330 | 2010-09-21 | 2010-11-26 | 2010-12-15 | 2011-01-20 | 1231 | M05 REACTOR QUENCH LIQUID PUMPS (P-21-/22201A/B) | KSB | EQ |  |  |  |  |  |  |  |  |  |  |  |  |  |  |  |
| P-22203 |  | REACTOR TEPID WATER PUMPS |  | 10d | 2012-04-19 | 2012-04-30 | ER291200 (other project), XM001330 SS, XM001330 FF, XC201330, XN201301l FS+5d, P3M06S2 (other project), XC911330 |  |  |  |  | -70d | 0d |  | Rotating Equipment (w/ lube oil unit) [3.75 t]; Rotating equipment (w/ lube oil unit) [328.12 h] | 14,996 |  | 328,13 |  | P-22203 | 328,12 | 0 |  |  | 13 |  |  |  |  | X | M |  | 1330 |  |  |  |  |  |  | VNZM |  |  |  | 3,75 | 3749 | concrete +0.00 | 2 PA 6540 / 5 | P-22203 | SK1330 | 2010-09-25 | 2010-11-26 | 2010-12-15 | 2011-01-20 | 1232 | M06 REACTOR TEPID WATER PUMPS (P-21-/22203) | KSB | EQ |  |  |  |  |  |  |  |  |  |  |  |  |  |  |  |
| XM001330 |  | CA13 OthGrBasedEqpt - Install Rotating Eqpt | level of effort | 10d | 2012-04-19 | 2012-04-30 |  |  |  |  |  | -70d | 0d |  |  |  |  | 16 |  | XM001330 | 0 | 0 |  | 934 | 13 | 200 | 200 | C | LND | X | M | XM00 | 1330 | M | 13 | X | EQ | LND | 1330 | VNZM | 2011-05-20 | E-08-01-10 |  |  |  |  |  |  |  |  |  |  |  |  |  |  |  | 2011-03-10 | XBB |  |  |  |  |  |  |  |  |  |  |  |  |  |
|  | E | **Electrical** |  |  | 2010-09-30 | 2012-08-15 |  |  |  |  |  |  |  |  |  |  |  |  |  |  |  |  |  |  |  |  |  |  |  |  |  |  |  |  |  |  |  |  |  |  |  |  |  |  |  |  |  |  |  |  |  |  |  |  |  |  |  |  |  |  |  |  |  |  |  |  |  |  |  |  |  |  |
| XC911330 |  | CA13 OthGrBasedEqpt - Install Earthing&Lightning_CIVIL |  | 40d | 2010-09-30 A | 2010-11-16 A | EE901330 (other project), IMS-C-000230 FF, XC201330 FF+10d | 100% |  |  |  |  |  |  | Grounding & Lightning [50 pcs]; Grounding & Lightning [562.5 h] | 22,500 | 22,500 | 562,50 |  | XC911330 | 562,5 | 562,5 |  | 934 | 13 | 200 | 200 | C | LND | X | C | XE91 | 1330 | C | 13 | X | EA | LND | 1330 | MO11 | 2011-11-30 | E-16-07-05 |  |  |  |  |  |  |  |  |  |  |  |  |  |  |  | 2011-05-10 |  |  |  |  |  |  |  |  |  |  |  |  |  |  |
| XE401330 |  | CA13 OthGrBasedEqpt - Install Cable Trays |  | 30d | 2011-10-31 | 2011-12-05 | XE401301 SF+10d, XR401330 SS+25d, EE46133010 (other project), XE405104 |  |  |  |  | 78d | 148d |  | Cable trays/conduits [180 m]; Cable trays [540 h] | 21,600 |  | 540,00 |  | XE401330 | 540 | 0 |  | 934 | 13 | 200 | 200 | C | LND | X | E | XE40 | 1330 | E | 13 | X | EL | LND | 1330 | URMA | 2011-08-20 | E-15-01-09 |  |  |  |  |  |  |  |  |  |  |  |  |  |  |  | 2011-05-10 |  | UDF_G3 | m | 300 | 2011-05-28 | 2011-08-06 | 2011-12-20 | 2011-07-20 | x | to be checked |  |  |  |  |
| XE801330 |  | CA13 OthGrBasedEqpt - Install Heat Tracing |  | 30d | 2012-03-10 | 2012-04-13 | XW501330 FF+20d, P3E19S (other project), E3E1950 (other project), XR401330, XR601330 FF+20d |  |  |  |  | 81d | 54d |  | Electrical Heat Tracing [800 m]; Electrical heat tracing [400 h] | 16,000 |  | 400,00 |  | XE801330 | 400 | 0 |  | 934 | 13 | 200 | 200 | C | LND | X | E | XE80 | 1330 | E | 13 | X | HT | LND | 1330 | URMA | 2012-03-20 | E-16-04-01 |  |  |  |  |  |  |  |  |  |  |  |  |  |  |  | 2011-06-20 |  |  |  |  |  |  | 2012-06-30 | 2011-09-15 |  |  | 005 |  |  |  |
| XE911331 |  | CA13 OthGrBasedEqpt - Install Earthing&Lightning_E/I |  | 10d | 2012-05-02 | 2012-05-14 | P-22201A/B, P-22203 |  |  |  |  | 40d | 127d |  |  |  |  | 55 |  | XE911331 | 0 | 0 |  | 934 | 13 | 200 | 200 | C | LND | X | E | XE91 | 1330 | E | 13 | X | EA | LND | 1330 | URMA | 2011-11-30 | E-16-07-05 |  |  |  |  |  |  |  |  |  |  |  |  |  |  |  | 2011-05-10 |  | UDF_G3 |  |  |  |  | 2012-04-15 | 2011-07-25 |  |  |  |  |  |  |
| XE341330 |  | CA13 OthGrBasedEqpt - Install Local Operation Panels |  | 20d | 2012-06-07 | 2012-06-30 | EE46133010 (other project), XE401330, XJ421330, XR401330 SS+25d, P-22201A/B, P-22203 |  |  |  |  | 231.5d |  |  | Field Panels [2 pcs]; Field panels [40 h] | 1,600 |  | 40,00 |  | XE341330 | 40 | 0 |  | 934 | 13 | 200 | 200 | C | LND | X | E | XE34 | 1330 | E | 13 | X | EL | LND | 1330 | URMA | 2011-11-30 | E-16-07-05 |  |  |  |  |  |  |  |  |  |  |  |  |  |  |  | 2011-05-10 |  | UDF_G3 |  |  |  |  | 2012-04-15 | 2011-07-25 |  |  |  |  |  |  |
| XE501330 |  | CA13 OthGrBasedEqpt - Cable Pulling Electric |  | 30d | 2012-06-18 | 2012-07-23 | P3E15AS (other project), XE500C01, P3E15BS (other project), XE401330, EE561330 (other project), XE505103 SS+10d, P3E15CS (other project), XE505104 SS+10d, XE505401 SS+12d, XE501301 SS |  |  |  |  | -41.5d | 0d | TB26 - V - Construct-Winter partly * | Cable Pulling [2200 m]; Cable pulling [1100 h] | 44,000 |  | 1100,00 |  | XE501330 | 1100 | 0 |  | 934 | 13 | 200 | 200 | C | LND | X | E | XE50 | 1330 | E | 13 | X | EL | LND | 1330 | URMA | 2012-02-10 | E-16-01-01 |  |  |  |  |  |  |  |  |  |  |  |  |  |  |  | 2011-05-20 |  | UDF_G3 | m | 2300 | 2011-09-06 | 2011-11-21 | 2012-07-01 | 2011-10-01 |  |  |  |  |  |  |
| XE601330 |  | CA13 OthGrBasedEqpt - Cable Termination &Testing |  | 50d | 2012-06-18 | 2012-08-15 | XE501330 FF+20d, XE341332, P-22201A/B, P-22203 |  |  |  |  | -41.5d | 11.5d | TB26 - V - Construct-Winter partly * | Cable connecting [20 pcs]; Cable connecting [50 h] | 2,000 |  | 50,00 |  | XE601330 | 50 | 0 |  | 934 | 13 | 200 | 200 | C | LND | X | E | XE60 | 1330 | E | 13 | X | ET | LND | 1330 | URMA | 2011-11-30 | E-16-02-01 |  |  |  |  |  |  |  |  |  |  |  |  |  |  |  | 2011-04-20 |  | UDF_G3 |  |  |  |  | 2012-08-14 | 2011-12-10 |  |  |  |  |  |  |
|  | R | **Piping** |  |  | 2011-07-19 | 2012-04-02 |  |  |  |  |  |  |  |  |  |  |  |  |  |  |  |  |  |  |  |  |  |  |  |  |  |  |  |  |  |  |  |  |  |  |  |  |  |  |  |  |  |  |  |  |  |  |  |  |  |  |  |  |  |  |  |  |  |  |  |  |  |  |  |  |  |  |
| XR201330 |  | CA13 OthGrBasedEqpt SK1310 - Piping Prefabrication |  | 115d | 2011-07-19 A | 2011-10-19 | XR200C00 FS+25d, ER491330 (other project) SS+12d |  | 46d | 2011-07-19 | 2011-11-30 | -26d | 4d |  | A/G piping prefabrication [1360 Fpi]; A/G Piping (Prefab) [5100 h] | 4,730.16 |  | 5100,00 | 27.8. | XR201330 | 5100 | 0 | x | 934 | 13 | 200 | 200 | C | LND | X | R | XR20 | 1330 | R | 13 | X | PRP | LND | 1330 | VNZM |  |  |  |  |  |  |  |  |  |  |  |  |  |  |  |  |  |  |  | UDF_G4 |  |  |  |  |  |  |  |  |  | x |  |  |
| XR401330 |  | CA13 OthGrBasedEqpt SK1310 - Piping Installation |  | 50d | 2011-10-01 | 2011-11-29 | XR201330 FS-20d, P3J02AS (other project) FF+20d, P3J04CS1 (other project), P3R03AS1 (other project) FF+20d, P3J02DS (other project) FF+20d, P3R07AS1 (other project), IMS-C-000190 FF, P3J04IS (other project) FF+20d, P3R04S1 (other project) FF+20d, XN201301u |  |  |  |  | -30d | 0d |  | A/G piping field installation [1650 Fpi]; Control & Shut-off valves [54 pcs]; A/G Piping (Field) [10312.5 h]; Install Control & Shut-off Valves [283.5 h] | 28,161.64 |  | 10596,00 |  | XR401330 | 10596 | 0 |  | 934 | 13 | 200 | 200 | C | LND | X | R | XR40 | 1330 | R | 13 | X | PI | LND | 1330 | VNZM |  | E-06-03-04 | 1 |  |  |  |  |  |  |  |  |  |  |  |  |  |  | 2011-01-20 |  |  |  |  |  |  |  |  |  |  |  |  | 2011-03-30 |  |
| XR601330 |  | CA13 OthGrBasedEqpt SK1310 - Piping Pressure Tests |  | 40d | 2012-02-02 | 2012-03-21 | XR401330 FF+20d, X0300020, XR605103 FF+20d |  |  |  |  | -99d | 0d |  |  |  |  | 375 |  | XR601330 | 0 | 0 |  | 934 | 13 | 200 | 200 | C | LND | X | R | XR60 | 1330 | R | 13 | X | HY | LND | 1330 | VNZM |  | E-06-03-04 |  |  |  |  |  |  |  |  |  |  |  |  |  |  |  |  |  |  |  |  |  |  |  |  |  |  |  |  |  |  |
| XR801330 |  | CA13 OthGrBasedEqpt SK1310 - Piping Reinstatement |  | 40d | 2012-02-14 | 2012-04-02 | XR601330 FF+10d, IMS-C-000360 FF |  |  |  |  | 14d | 84d |  |  |  |  | 188 |  | XR801330 | 0 | 0 |  | 934 | 13 | 200 | 200 | C | LND | X | R | XR80 | 1330 | R | 13 | X | PI | LND | 1330 | VNZM | 2011-11-30 | E-06-03-04 |  |  |  |  |  |  |  |  |  |  |  |  |  |  |  |  |  |  |  |  |  |  |  |  |  |  |  |  |  | 2012-02-11 |

Notes:
- XW501322: P3 Activity Log Info: Clarification Surface Protection during Prefab
- XR401330: Current Status: 110803 (WL): Delete Pred. P-22201A/B REACTOR QUENCH LIQUID PUMPS and P-22203 REACTOR TEPID WATER PUMPS

| ID | WBS | Activity | Type | Duration | Start | Finish | Predecessors | Complete | Total float | Free float | Constraint | Calendar | Resources | Cost | TB26 Ressource Budget | UDF_CONTRACT START DATE | UDF_CONTRACT FINISH DATE | UDF_CONTRACT ITEM | UDF_CONTRACT INDICATOR | UDF_CONTRACT FINISH DATE REV1 | UDF_CONTRACT START DATE REV1 | UDF_SAVE ACT ID | UDF_BUDGETED LABOR UNIT | UDF_ACTUAL LABOR UNIT | UDF_COMMENTS_0827 | Department | Constr. Area | PMT-Area | PMT-Schedule Org | PMT-Phase | PMT-Respons. | WBS Phase | WBS Discipline | WBS Type of Work | WBS Objects | Russia WBS Discipline (Russia) | Russia Construction Area | Russia WBS Phase | IMS | UPT | Russia WBS Objects | Subcontractor | TB26 Semantics | TB26 Material Res Values | UDF_ELECTRICAL START | UDF_ELECTRICAL FINISH | UDF_CHECK BASELINE | UDF_PENALIZED FINISH | UDF_Weight (ton) | WEIGHT | UDF_LEVEL | UDF_PO No | UDF_TAG No | UDF_Object No | UDF_DELIVERY DATE PO | UDF_DELIVERY DATE DISPATCH PLANNED | UDF_DELIVERY DATE TO SITE PLANNED | UDF_DELIVERY DATE SITE NEED DATE | UDF_SHIPMENT No | UDF_PACKAGE | UDF_SUPPLIER | UDF_Vendor Representatives | UDF_SELECT UPDATE PROGRESS | Zeigen/n. Zeigen | Type of Work |
| --- | --- | --- | --- | --- | --- | --- | --- | --- | --- | --- | --- | --- | --- | --- | --- | --- | --- | --- | --- | --- | --- | --- | --- | --- | --- | --- | --- | --- | --- | --- | --- | --- | --- | --- | --- | --- | --- | --- | --- | --- | --- | --- | --- | --- | --- | --- | --- | --- | --- | --- | --- | --- | --- | --- | --- | --- | --- | --- | --- | --- | --- | --- | --- | --- | --- |
|  | J | **Instrumentation** |  |  | 2012-05-02 | 2012-10-25 |  |  |  |  |  |  |  |  |  |  |  |  |  |  |  |  |  |  |  |  |  |  |  |  |  |  |  |  |  |  |  |  |  |  |  |  |  |  |  |  |  |  |  |  |  |  |  |  |  |  |  |  |  |  |  |  |  |  |  |
| XJ301330 |  | CA13 OthGrBasedEqpt - Install Field Instruments |  | 60d | 2012-05-02 | 2012-07-12 | XR801330 FF, P3J05S (other project), P3J04AS (other project), EJ361330 (other project), P3J04BS (other project), XR401330 SS+25d, P-22201A/B, P-22203 |  | -70d | 0d |  |  | Field Instruments [110 pcs]; Install field instruments [604 h] | 24,200 | 604,00 | 2011-05-10 | 2012-03-20 | E-17-04-05 | UDF_G3 | 2012-08-15 | 2011-07-25 | XJ301330 | 604 | 0 | to be checked | 934 | 13 | 200 | 200 | C | LND | X | J | XJ30 | 1330 | J | 13 | X | IN | LND | 1330 | URMA |  |  |  |  |  |  |  |  |  |  |  |  |  |  |  |  |  |  |  |  |  |  |  |
| XJ321330 |  | CA13 OthGrBasedEqpt - Install Junction Boxes |  | 10d | 2012-05-02 | 2012-05-14 | P3J06ES (other project) FS+14d, P3J06FS (other project), EJ321330 (other project), XR401330 SS+25d, P-22201A/B, P-22203 |  | -70d | 0d |  |  | Junction Boxes/Cabinets/Panels [18 pcs]; Install Junction Boxes/ Cabinets/ Panels [450 h] | 18,000 | 450,00 | 2011-05-10 | 2012-03-20 | E-17-04-05 | UDF_G3 | 2012-08-15 | 2011-07-25 | XJ321330 | 450 | 0 | to be installed later | 934 | 13 | 200 | 200 | C | LND | X | J | XJ32 | 1330 | J | 13 | X | IN | LND | 1330 | URMA |  |  |  |  |  |  |  |  |  |  |  |  |  |  |  |  |  |  |  |  |  |  |  |
| XJ421330 |  | CA13 OthGrBasedEqpt - Install Secondary CableTrays |  | 30d | 2012-05-02 | 2012-06-06 | EJ46133010 (other project), XJ321330 FF+20d, XE401330 FF, XR401330 SS+25d, P-22201A/B, P-22203 |  | -70d | 0d |  |  | Secondary cable trays [190 m]; Install secondary cable trays [712.5 h] | 28,500 | 712,50 | 2011-05-10 | 2011-08-20 | E-15-01-09 |  | 2011-12-20 | 2011-07-20 | XJ421330 | 712,5 | 0 | to be installed later | 934 | 13 | 200 | 200 | C | LND | X | J | XJ42 | 1330 | J | 13 | X | IN | LND | 1330 | URMA | m | 330 | 2011-05-28 | 2011-08-06 | x |  |  |  |  |  |  |  |  |  |  |  |  |  |  |  |  |  |  |
| XJ441330 |  | CA13 OthGrBasedEqpt - Install Conduits to Instrm |  | 60d | 2012-06-07 | 2012-08-16 | XJ321330, P-22201A/B, P-22203, XR401330 SS+25d, XE401330, XJ421330 |  | -70d | 0d |  |  |  |  |  | 2011-05-10 | 2012-03-20 | E-17-04-05 |  | 2012-08-15 | 2011-07-25 | XJ441330 | 0 | 0 | to be installed later | 934 | 13 | 200 | 200 | C | LND | X | J | XJ44 | 1330 | J | 13 | X | IN | LND | 1330 | URMA |  |  |  |  |  |  |  |  |  |  |  |  |  |  |  |  |  |  |  |  |  |  |  |
| XJ521330 |  | CA13 OthGrBasedEqpt - Pulling Multicore Cables |  | 40d | 2012-06-07 | 2012-07-25 | XE500C01, XJ525103 SS+12d, XJ321330 SS+20d, XE401330, XJ521301 SS, XJ525401 SS+18d, XJ525102 SS+15d, XJ525104 SS+10d |  | -13.5d | 0d |  | TB26 - V - Construct-Winter partly * | Multicore cables [3900 m]; Pull multicore cables [1950 h] | 78,000 | 1950,00 | 2011-05-20 | 2012-03-10 | E-17-01-01 |  | 2012-06-16 | 2011-11-01 | XJ521330 | 1950 | 0 | to be checked | 934 | 13 | 200 | 200 | C | LND | X | J | XJ52 | 1330 | J | 13 | X | IN | LND | 1330 | URMA | m | 2850 | 2011-10-01 | 2011-11-17 |  |  |  |  |  |  |  |  |  |  |  |  |  |  |  |  |  |  |  |
| XJ541330 |  | CA13 OthGrBasedEqpt - Pulling Singlecore Cables |  | 40d | 2012-06-20 | 2012-08-04 | XE500C01, XJ421330, XJ301330 FF+10d, XJ441330 SS+10d, EJ801330 (other project) |  | -45d | 25d |  | TB26 - V - Construct-Winter partly * | Singlecore cables [9900 m]; Pull singlecore cables [7425 h] | 297,000 | 7425,00 | 2011-05-10 | 2012-03-20 | E-17-04-05 |  | 2012-08-15 | 2011-07-25 | XJ541330 | 7425 | 0 |  | 934 | 13 | 200 | 200 | C | LND | X | J | XJ54 | 1330 | J | 13 | X | IN | LND | 1330 | URMA | m | 9520 | 2011-10-28 | 2011-12-21 |  |  |  |  |  |  |  |  |  |  |  |  |  |  |  |  |  |  |  |
| XJ701330 |  | CA13 OthGrBasedEqpt - Instrument Tubing |  | 40d | 2012-06-20 | 2012-08-04 | XJ301330 FF+20d, XR401330 |  | -70d | 0d |  |  |  |  |  | 2011-05-10 | 2012-03-20 | E-17-04-05 |  | 2012-08-15 | 2011-07-25 | XJ701330 | 0 | 0 |  | 934 | 13 | 200 | 200 | C | LND | X | J | XJ70 | 1330 | J | 13 | X | IN | LND | 1330 | URMA |  |  |  |  |  |  |  |  |  |  |  |  |  |  |  |  |  |  |  |  |  |  |  |
| XJ621330 |  | CA13 OthGrBasedEqpt - Termin Multicore Cables |  | 40d | 2012-06-20 | 2012-08-06 | XJ521330 FF+10d, XJ321330 |  | -13.5d | 59.5d |  |  | Termination Field [705 mhr]; Termination field [705 h] | 70,500 | 705,00 | 2011-05-20 | 2012-03-10 | E-17-01-01 |  | 2012-06-16 | 2011-11-01 | XJ621330 | 705 | 0 |  | 934 | 13 | 200 | 200 | C | LND | X | J | XJ62 | 1330 | J | 13 | X | IN | LND | 1330 | URMA |  |  |  |  |  |  |  |  |  |  |  |  |  |  |  |  |  |  |  |  |  |  |  |
| XJ391330 |  | CA13 OthGrBasedEqpt - Install Earthing Field Eqp |  | 40d | 2012-07-13 | 2012-08-28 | XJ301330 FS-30d, XJ441330 FS-30d, XJ421330 FS-15d |  | -70d | 0d |  |  |  |  |  | 2011-05-10 | 2012-03-20 | E-17-04-05 |  | 2012-08-15 | 2011-07-25 | XJ391330 | 0 | 0 |  | 934 | 13 | 200 | 200 | C | LND | X | J | XJ39 | 1330 | J | 13 | X | IN | LND | 1330 | URMA |  |  |  |  |  |  |  |  |  |  |  |  |  |  |  |  |  |  |  |  |  |  |  |
| XJ641330 |  | CA13 OthGrBasedEqpt - Termin Singlecore Cables |  | 40d | 2012-08-06 | 2012-09-20 | XJ541330 FF+15d, XJ301330, XJ321330, XJ391330 FS-20d, XJ701330 |  | -70d | 17d |  | TB26 - V - Construct-Winter partly * | Termination Field [705 mhr]; Termination field [705 h] | 70,500 | 705,00 | 2011-05-10 | 2012-03-20 | E-17-04-05 |  | 2012-08-15 | 2011-07-25 | XJ641330 | 705 | 0 |  | 934 | 13 | 200 | 200 | C | LND | X | J | XJ64 | 1330 | J | 13 | X | IN | LND | 1330 | URMA |  |  |  |  |  |  |  |  |  |  |  |  |  |  |  |  |  |  |  |  |  |  |  |
| XJ801330 |  | CA13 OthGrBasedEqpt - Inspections/ Mech. Acceptance/ Loop Checks |  | 50d | 2012-08-29 | 2012-10-25 | X030410030, EJ801330 (other project), XJ641330 FF+10d, XJ391330, X3J120, IMS-C-000420 FF, XE601330, XJ701330 SS, XJ621330 FF+10d |  | -53d | 42.5d |  |  | Loop Checks [350 pcs]; Loop checks [1750 h] | 70,000 | 1750,00 | 2011-06-10 | 2012-04-30 | E-17-02-01 |  | 2012-08-18 | 2012-03-01 | XJ801330 | 1750 | 0 |  | 934 | 13 | 200 | 200 | C | LND | X | J | XJ80 | 1330 | J | 13 | X | LT | LND | 1330 | URMA |  |  |  |  |  | 2012-08-18 |  |  |  |  |  |  |  |  |  |  |  |  |  |  |  |  |  |
|  | W | **Painting** |  |  | 2011-08-27 | 2011-11-05 |  |  |  |  |  |  |  |  |  |  |  |  |  |  |  |  |  |  |  |  |  |  |  |  |  |  |  |  |  |  |  |  |  |  |  |  |  |  |  |  |  |  |  |  |  |  |  |  |  |  |  |  |  |  |  |  |  |  |  |
| XW501330 |  | CA13 OthGrBasedEqpt - Surf.Protection Piping |  | 60d | 2011-08-27 | 2011-11-05 | XR201330 FF+10d |  | 190d | 109d |  |  | Piping painting [473 sqm]; Piping painting [1182 h] | 620.83 | 1182,00 |  |  |  |  |  |  | XW501330 | 1182 | 0 |  | 934 | 13 | 200 | 200 | C | LND | X | W | XW50 | 1330 | W | 13 | X | PA | LND | 1330 | VNZM |  |  |  |  |  |  |  |  |  |  |  |  |  |  |  |  |  |  |  |  |  |  |  |
|  | V | **Insulation** |  |  | 2012-05-02 | 2012-07-24 |  |  |  |  |  |  |  |  |  |  |  |  |  |  |  |  |  |  |  |  |  |  |  |  |  |  |  |  |  |  |  |  |  |  |  |  |  |  |  |  |  |  |  |  |  |  |  |  |  |  |  |  |  |  |  |  |  |  |  |
| XV301330 |  | CA13 OthGrBasedEqpt - Insulation Equipment |  | 60d | 2012-05-02 | 2012-07-12 | P-22203, P-22201A/B, XE801330 FF+15d |  | 27d | 0d |  |  | Equipment insulation [200 sqm]; Equipment insulation [2500 h] | 443.45 | 2500,00 |  | 2012-03-30 | E-13-03 |  |  |  | XV301330 | 2500 | 0 |  | 934 | 13 | 200 | 200 | C | LND | X | V | XV30 | 1330 | V | 13 | X | INS | LND | 1330 | VNZM |  |  |  |  |  |  |  |  |  |  |  |  |  |  |  |  |  |  |  |  |  |  |  |
| XV501330 |  | CA13 OthGrBasedEqpt - Insulation Piping |  | 60d | 2012-05-15 | 2012-07-24 | XV301330 FF+10d, XE801330 FF+30d, XR601330 SS |  | 27d | 122.5d |  |  | Piping insulation [450 sqm]; Piping insulation [3375 h] | 1,773.81 | 3375,00 |  | 2012-04-30 | E-13-01 |  |  |  | XV501330 | 3375 | 0 |  | 934 | 13 | 200 | 200 | C | LND | X | V | XV50 | 1330 | V | 13 | X | INS | LND | 1330 | VNZM |  |  |  |  |  |  |  |  |  |  |  |  |  |  |  |  |  |  |  |  |  |  |  |
|  | 31 | **CA13 - Reactor** |  |  |  |  |  |  |  |  |  |  |  |  |  |  |  |  |  |  |  |  |  |  |  |  |  |  |  |  |  |  |  |  |  |  |  |  |  |  |  |  |  |  |  |  |  |  |  |  |  |  |  |  |  |  |  |  |  |  |  |  |  |  |  |
|  | 32 | **CA13 - Recycle Gas Compressor** |  |  | 2010-09-30 | 2012-11-03 |  |  |  |  |  |  |  |  |  |  |  |  |  |  |  |  |  |  |  |  |  |  |  |  |  |  |  |  |  |  |  |  |  |  |  |  |  |  |  |  |  |  |  |  |  |  |  |  |  |  |  |  |  |  |  |  |  |  |  |
|  | C | **Civil Work** |  |  | 2010-09-30 | 2010-10-28 |  |  |  |  |  |  |  |  |  |  |  |  |  |  |  |  |  |  |  |  |  |  |  |  |  |  |  |  |  |  |  |  |  |  |  |  |  |  |  |  |  |  |  |  |  |  |  |  |  |  |  |  |  |  |  |  |  |  |  |
| XC201332 |  | CA13 R.G.Compressor - Concrete Works Foundation |  | 25d | 2010-09-30 A | 2010-10-28 A | EC281332 (other project) FS+10d, XC20130410 SS | 100% |  |  |  | TB26 - V - Construct-Winter partly * | Concrete works [150 cbm]; Concrete works [4500 h] | 1,847.72 | 4500,00 |  |  |  |  |  |  | XC201332 | 4500 | 4500 |  | 934 | 13 | 200 | 200 | C | MO01 | X | C | XC20 | 1332 | C | 13 | X | mis | LND | 1332 | MO11 |  |  |  |  |  |  |  |  |  |  |  |  |  |  |  |  |  |  |  |  |  |  |  |
|  | B | **Mechanical - Stationary Equipment** |  |  |  |  |  |  |  |  |  |  |  |  |  |  |  |  |  |  |  |  |  |  |  |  |  |  |  |  |  |  |  |  |  |  |  |  |  |  |  |  |  |  |  |  |  |  |  |  |  |  |  |  |  |  |  |  |  |  |  |  |  |  |  |
|  | M | **Mechanical - Rotating Equipment** |  |  | 2011-08-02 | 2011-08-12 |  |  |  |  |  |  |  |  |  |  |  |  |  |  |  |  |  |  |  |  |  |  |  |  |  |  |  |  |  |  |  |  |  |  |  |  |  |  |  |  |  |  |  |  |  |  |  |  |  |  |  |  |  |  |  |  |  |  |  |
| K-22201A/B |  | RECYCLE GAS COMPRESSOR |  | 10d | 2011-08-02 A | 2011-08-12 A | XC201332, XM101332 FF, XM101332 SS, P3M02S2 (other project), XC911332, XC201332 FF | 100% |  |  | start on or after 2011-08-02 |  | Rotating Equipment (w/ lube oil unit) [19.7 t]; Rotating equipment (w/ lube oil unit) [1638.35 h] | 78,800 | 1568,00 |  |  |  | UDF_G4 |  |  | K-22201A/B | 1638,35 | 0 |  |  | 13 |  |  |  |  | X | M |  | 1332 |  |  |  |  |  |  | VNZM |  |  |  |  |  |  | 17,124 | 8562 | concrete +0.00 | 2 DC 8490 | K-22201A/B | SK1332 | 2009-12-18 | 2010-11-30 | 2010-12-15 | 2010-11-20 | 1174-1176/1278 | M02 RECYCLE GAS COMPRESSOR (K-21-/22201A/B) | Sundstrand | 031 | 27.8. | EQ |  |
| XM101332 |  | CA13 R.G.Compressor - Install Rotating Eqpt | level of effort | 10d | 2011-08-02 A | 2011-08-12 A |  | 100% |  |  |  | TB26 - V - Construct-Winter partly * |  |  | 19 | 2011-03-10 | 2011-05-20 | E-08-01-10 |  |  |  | XM101332 | 0 | 0 |  | 934 | 13 | 200 | 200 | C | LND | X | M | XM10 | 1332 | M | 13 | X | EQ | LND | 1332 | VNZM |  |  |  |  |  |  |  |  |  |  |  |  |  |  |  |  |  |  |  | 031 | 27.8. |  | XBB |

Notes:
- XJ321330: Current Status: 110803 (WL): Delete PRED P-22201A/B REACTOR QUENCH LIQUID PUMPS and P-22203 REACTOR TEPID WATER PUMPS
- XJ521330: Current Status: 110830: Delete PRED XJ701330 Instrument Tubing (M. / Oettel)
- XJ391330: Current Status: 110831: Delete PRED XJ381330 Install Analyser House
- XW501330: P3 Activity Log Info: Clarification Surface Protection during Prefab

| ID | WBS | Activity | Duration | Start | Finish | Predecessors | Complete | Remaining | Total float | Free float | Constraint | Calendar | Resources | Cost | Actual cost | TB26 Ressource Budget | UDF_CONTRACT INDICATOR | UDF_SELECT UPDATE PROGRESS | UDF_SAVE ACT ID | UDF_BUDGETED LABOR UNIT | UDF_ACTUAL LABOR UNIT | UDF_CHECK RESOURCE DATES | Department | Constr. Area | PMT-Area | PMT-Schedule Org | PMT-Phase | PMT-Respons. | WBS Phase | WBS Discipline | WBS Type of Work | WBS Objects | Russia WBS Discipline (Russia) | Russia Construction Area | Russia WBS Phase | IMS | UPT | Russia WBS Objects | 4 week lookahead | Subcontractor | UDF_CONTRACT START DATE | UDF_CONTRACT ITEM | UDF_PLANNED START | UDF_CONTRACT FINISH DATE | UDF_PLANNED FINISH | UDF_CONTRACT FINISH DATE REV1 | UDF_CONTRACT START DATE REV1 | TB26 Semantics | TB26 Material Res Values | UDF_ELECTRICAL START | UDF_ELECTRICAL FINISH | UDF_CHECK BASELINE | UDF_Vendor Representatives | UDF_COMMENTS_0827 | UDF_PENALIZED FINISH |
| --- | --- | --- | --- | --- | --- | --- | --- | --- | --- | --- | --- | --- | --- | --- | --- | --- | --- | --- | --- | --- | --- | --- | --- | --- | --- | --- | --- | --- | --- | --- | --- | --- | --- | --- | --- | --- | --- | --- | --- | --- | --- | --- | --- | --- | --- | --- | --- | --- | --- | --- | --- | --- | --- | --- | --- |
|  | R | **Piping** |  | 2011-07-28 | 2012-04-02 |  |  |  |  |  |  |  |  |  |  |  |  |  |  |  |  |  |  |  |  |  |  |  |  |  |  |  |  |  |  |  |  |  |  |  |  |  |  |  |  |  |  |  |  |  |  |  |  |  |  |
| XR201332 |  | CA13 R.G.Compressor - Piping Prefabrication | 62d | 2011-07-28 A | 2011-10-07 | P3R06BS1 (other project) FS+10d, P3R06DS1 (other project), ER491332 (other project) FS+6d, P3R06S1 (other project) |  | 36d | -10d | 448.5d |  |  | A/G piping prefabrication [950 Fpi]; A/G Piping (Prefab) [3562.5 h] | 3,311.11 |  | 3562,50 | UDF_G4 | 27.8. | XR201332 | 3562,5 | 0 | x | 934 | 13 | 200 | 200 | C | LND | X | R | XR20 | 1332 | R | 13 | X | PRP | LND | 1332 | x | VNZM |  |  |  |  |  |  |  |  |  |  |  |  |  |  |  |
| XR401332 |  | CA13 R.G.Compressor - Piping Installation | 50d | 2011-10-13 | 2011-12-10 | P3S01S (other project) FS+20d, P3S02S (other project) FF, P3J04IS (other project) FF+20d, XR201332 SS+20d, P3R09BS (other project) FF+20d, P3J01AS (other project) FF+20d, P3J02S (other project) FF+10d, K-22201A/B FF+10d, IMS-C-000190 FF, P3J02AS (other project) FF+20d, P3J02DS (other project) FF+20d, P3J04CS1 (other project), XN201301u FS+10d |  |  | -50d | 0d |  |  | A/G piping field installation [1150 Fpi]; Control & Shut-off valves [26 pcs]; A/G Piping (Field) [7187.5 h]; Install Control & Shut-off Valves [136.5 h] | 17,226.28 |  | 7324,00 |  |  | XR401332 | 7324 | 0 |  | 934 | 13 | 200 | 200 | C | LND | X | R | XR40 | 1332 | R | 13 | X | PI | LND | 1332 |  | VNZM | 2011-01-20 | E-06-03-04 | 2011-03-30 |  |  |  |  |  |  |  |  |  |  |  |  |
| XR801332 |  | CA13 R.G.Compressor - Piping Reinstatement | 60d | 2012-01-21 | 2012-04-02 | XR601332 FF+10d, IMS-C-000360 FF |  |  | 1d | 0d |  |  |  |  |  | 131 |  |  | XR801332 | 0 | 0 |  | 934 | 13 | 200 | 200 | C | LND | X | R | XR80 | 1332 | R | 13 | X | PI | LND | 1332 |  | VNZM |  | E-06-03-04 |  | 2011-11-30 | 2012-02-11 |  |  |  |  |  |  |  |  |  |  |
| XR601332 |  | CA13 R.G.Compressor - Piping Pressure Tests | 30d | 2012-02-14 | 2012-03-21 | XR401332 FF+20d, XR605103 FF+20d |  |  | -109d | 0d |  |  |  |  |  | 263 |  |  | XR601332 | 0 | 0 |  | 934 | 13 | 200 | 200 | C | LND | X | R | XR60 | 1332 | R | 13 | X | HY | LND | 1332 |  | VNZM |  | E-06-03-04 |  |  |  |  |  |  |  |  |  |  |  |  |  |
|  | E | **Electrical** |  | 2010-09-30 | 2012-08-15 |  |  |  |  |  |  |  |  |  |  |  |  |  |  |  |  |  |  |  |  |  |  |  |  |  |  |  |  |  |  |  |  |  |  |  |  |  |  |  |  |  |  |  |  |  |  |  |  |  |  |
| XC911332 |  | CA13 R.G.Compressor - Install Earthing&LightnSys_CIVIL | 39d | 2010-09-30 A | 2010-11-15 A | XC201332 FF+10d, EE901332 (other project) | 100% |  |  |  |  |  | Grounding & Lightning [50 pcs]; Grounding & Lightning [562.5 h] | 22,500 | 22,500 | 562,50 |  |  | XC911332 | 562,5 | 562,5 |  | 934 | 13 | 200 | 200 | C | LND | X | C | XE91 | 1332 | C | 13 | X | EA | LND | 1332 |  | MO11 | 2011-05-10 | E-16-07-05 |  | 2011-11-30 |  |  |  |  |  |  |  |  |  |  |  |
| XE911333 |  | CA13 R.G.Compressor - Install Earthing&LightnSys_E/I | 5d | 2011-09-12 | 2011-09-16 | K-22201A/B FS+25d |  |  | 235d | 322d |  |  |  |  |  | 55 | UDF_G3 |  | XE911333 | 0 | 0 |  | 934 | 13 | 200 | 200 | C | LND | X | E | XE91 | 1332 | E | 13 | X | EA | LND | 1332 |  | URMA | 2011-05-10 | E-16-07-05 |  | 2011-11-30 |  | 2012-04-15 | 2011-07-25 |  |  |  |  |  |  |  |  |
| XE401332 |  | CA13 R.G.Compressor - Install Cable Trays | 30d | 2011-11-18 | 2011-12-22 | XE401301 SS+6d, EE46133210 (other project), XN201301u FS+10d, XR401332 SS+30d |  |  | 43d | 0d |  |  | Cable trays/conduits [180 m]; Cable trays [540 h] | 21,600 |  | 540,00 | UDF_G3 |  | XE401332 | 540 | 0 |  | 934 | 13 | 200 | 200 | C | LND | X | E | XE40 | 1332 | E | 13 | X | EL | LND | 1332 |  | URMA | 2011-05-10 | E-15-01-09 |  | 2011-08-20 |  | 2011-12-20 | 2011-07-20 | m | 300 | 2011-08-03 | 2011-10-11 | x |  |  |  |
| XE341332 |  | CA13 R.G.Compressor - Install Local Operation Panels | 10d | 2011-12-23 | 2012-01-10 | XJ421332, XE401332, EE46133210 (other project), XR401332 SS+25d, K-22201A/B |  |  | 90d | 131.5d |  |  | Field Panels [1 pcs]; Field panels [20 h] | 800 |  | 20,00 | UDF_G3 |  | XE341332 | 20 | 0 |  | 934 | 13 | 200 | 200 | C | LND | X | E | XE34 | 1332 | E | 13 | X | EL | LND | 1332 |  | URMA | 2011-05-10 | E-16-07-05 |  | 2011-11-30 |  | 2012-04-15 | 2011-07-25 |  |  |  |  |  |  |  |  |
| XE801332 |  | CA13 R.G.Compressor - Install Heat Tracing | 30d | 2012-04-14 | 2012-05-21 | XW501332 FF+20d, K-22201A/B FS+10d, E3E1950 (other project), P3E19S (other project), XR401332, XR601332 FF+15d |  |  | 1d | 0d |  |  | Electrical Heat Tracing [800 m]; Electrical heat tracing [400 h] | 16,000 |  | 400,00 | UDF_G3 |  | XE801332 | 400 | 0 |  | 934 | 13 | 200 | 200 | C | LND | X | E | XE80 | 1332 | E | 13 | X | HT | LND | 1332 |  | URMA | 2011-06-20 | E-16-04-01 |  | 2012-03-20 |  | 2012-06-30 | 2011-09-15 |  |  |  |  |  | 005 |  |  |
| XE501332 |  | CA13 R.G.Compressor - Cable Pulling Electric | 30d | 2012-06-18 | 2012-07-23 | XE505103 SS+10d, EE561332 (other project), XE500C01, XE401332, XE505104 SS+10d, XE505401 SS+12d, XE501301 SS |  |  | -51.5d | 0d |  | TB26 - V - Construct-Winter partly * | Cable Pulling [2200 m]; Cable pulling [1100 h] | 44,000 |  | 1100,00 | UDF_G3 |  | XE501332 | 1100 | 0 |  | 934 | 13 | 200 | 200 | C | LND | X | E | XE50 | 1332 | E | 13 | X | EL | LND | 1332 |  | URMA | 2011-05-20 | E-16-01-01 |  | 2012-02-10 |  | 2012-07-01 | 2011-10-01 | m | 2300 | 2011-10-12 | 2012-04-05 |  |  |  |  |
| XE601332 |  | CA13 R.G.Compressor - Cable Termination &Testing | 50d | 2012-06-18 | 2012-08-15 | XE501332 FF+20d, XE341332 FF+20d, K-22201A/B |  |  | -51.5d | 9d |  | TB26 - V - Construct-Winter partly * | Cable connecting [20 pcs]; Cable connecting [50 h] | 2,000 |  | 50,00 | UDF_G3 |  | XE601332 | 50 | 0 |  | 934 | 13 | 200 | 200 | C | LND | X | E | XE60 | 1332 | E | 13 | X | ET | LND | 1332 |  | URMA | 2011-04-20 | E-16-02-01 |  | 2011-11-30 |  | 2012-08-14 | 2011-12-10 |  |  |  |  |  |  |  |  |
|  | J | **Instrumentation** |  | 2011-11-12 | 2012-11-03 |  |  |  |  |  |  |  |  |  |  |  |  |  |  |  |  |  |  |  |  |  |  |  |  |  |  |  |  |  |  |  |  |  |  |  |  |  |  |  |  |  |  |  |  |  |  |  |  |  |  |
| XJ321332 |  | CA13 R.G.Compressor - Install Junction Boxes | 15d | 2011-11-12 | 2011-11-29 | EJ321332 (other project), P3J06FS (other project), P3J06ES (other project) FS+14d, K-22201A/B, XR401332 SS+25d |  |  | 56d | 13d | start on or after 2011-10-03 |  | Junction Boxes/Cabinets/Panels [18 pcs]; Install Junction Boxes/ Cabinets/ Panels [450 h] | 18,000 |  | 450,00 |  |  | XJ321332 | 450 | 0 |  | 934 | 13 | 200 | 200 | C | LND | X | J | XJ32 | 1332 | J | 13 | X | IN | LND | 1332 |  | URMA | 2011-05-10 | E-17-04-05 |  | 2012-03-20 |  | 2012-08-15 | 2011-07-25 |  |  |  |  |  |  | to be installed later |  |
| XJ421332 |  | CA13 R.G.Compressor - Install Secondary Cable Trays | 20d | 2011-11-30 | 2011-12-22 | EJ46133210 (other project), XE401332 FF, XJ321332 FF+7d, XR401332 SS+25d, K-22201A/B |  |  | 43d | 0d |  |  | Secondary cable trays [130 m]; Install secondary cable trays [487.5 h] | 19,500 |  | 487,50 |  |  | XJ421332 | 487,5 | 0 |  | 934 | 13 | 200 | 200 | C | LND | X | J | XJ42 | 1332 | J | 13 | X | IN | LND | 1332 |  | URMA | 2011-05-10 | E-15-01-09 |  | 2011-08-20 |  | 2011-12-20 | 2011-07-20 | m | 220 | 2011-08-03 | 2011-10-11 | x |  | to be installed later |  |
| XJ441332 |  | CA13 R.G.Compressor - Install Conduits to Instrm | 40d | 2011-12-23 | 2012-02-14 | XJ321332, XR401332 SS+25d, XE401332, XJ421332, K-22201A/B |  |  | 43d | 29d |  |  |  |  |  |  |  |  | XJ441332 | 0 | 0 |  | 934 | 13 | 200 | 200 | C | LND | X | J | XJ44 | 1332 | J | 13 | X | IN | LND | 1332 |  | URMA | 2011-05-10 | E-17-04-05 |  | 2012-03-20 |  | 2012-08-15 | 2011-07-25 |  |  |  |  |  |  | to be installed later |  |
| XJ301332 |  | CA13 R.G.Compressor - Install Field Instruments | 60d | 2012-01-21 | 2012-04-02 | P3J04ES (other project), P3J13S (other project), XR801332 FF, P3J05S (other project), P3J13BS (other project), P3J14AS (other project), EJ361332 (other project), P3J12DS (other project), P3J13AS (other project), P3J12BS (other project), P3J13CS (other project), P3J14S (other project), P3J04BS (other project), P3J04AS (other project), P3J14BS (other project), XR401332 SS+25d, K-22201A/B |  |  | 14d | 0d |  |  | Field Instruments [115 pcs]; Install field instruments [633 h] | 25,300 |  | 633,00 | UDF_G3 |  | XJ301332 | 633 | 0 |  | 934 | 13 | 200 | 200 | C | LND | X | J | XJ30 | 1332 | J | 13 | X | IN | LND | 1332 |  | URMA | 2011-05-10 | E-17-04-05 |  | 2012-03-20 |  | 2012-08-15 | 2011-07-25 |  |  |  |  |  |  | to be checked |  |
| XJ541332 |  | CA13 R.G.Compressor - Pulling Singlecore Cables | 40d | 2012-02-14 | 2012-04-13 | XJ441332 SS+10d, XJ421332, EJ801332 (other project), XJ301332 FF+10d, XE500C01 |  |  | 49d | 35d |  | TB26 - V - Construct-Winter partly * | Singlecore cables [9900 m]; Pull singlecore cables [7425 h] | 297,000 |  | 7425,00 |  |  | XJ541332 | 7425 | 0 |  | 934 | 13 | 200 | 200 | C | LND | X | J | XJ54 | 1332 | J | 13 | X | IN | LND | 1332 |  | URMA | 2011-05-10 | E-17-04-05 |  | 2012-03-20 |  | 2012-08-15 | 2011-07-25 | m | 9520 | 2011-10-14 | 2012-03-12 |  |  |  |  |
| XJ391332 |  | CA13 R.G.Compressor - Install Earthing Field Eqp | 30d | 2012-03-22 | 2012-04-25 | XJ301332 FF+20d, XJ421332, XJ441332 |  |  | 14d | 0d |  |  |  |  |  |  |  |  | XJ391332 | 0 | 0 |  | 934 | 13 | 200 | 200 | C | LND | X | J | XJ39 | 1332 | J | 13 | X | IN | LND | 1332 |  | URMA | 2011-05-10 | E-17-04-05 |  | 2012-03-20 |  | 2012-08-15 | 2011-07-25 |  |  |  |  |  |  |  |  |
| XJ701332 |  | CA13 R.G.Compressor - Instrument Tubing | 30d | 2012-03-22 | 2012-04-25 | XJ301332 FF+20d, XR401332 |  |  | 14d | 0d |  |  |  |  |  |  |  |  | XJ701332 | 0 | 0 |  | 934 | 13 | 200 | 200 | C | LND | X | J | XJ70 | 1332 | J | 13 | X | IN | LND | 1332 |  | URMA | 2011-05-10 | E-17-04-05 |  | 2012-03-20 |  | 2012-08-15 | 2011-07-25 |  |  |  |  |  |  |  |  |
| XJ641332 |  | CA13 R.G.Compressor - Termin Singlecore Cables | 40d | 2012-04-26 | 2012-06-14 | XJ541332 FF+15d, XJ301332, XJ391332, XJ321332, XJ701332 |  |  | 14d | 101d |  | TB26 - V - Construct-Winter partly * | Termination Field [705 mhr]; Termination field [705 h] | 70,500 |  | 705,00 |  |  | XJ641332 | 705 | 0 |  | 934 | 13 | 200 | 200 | C | LND | X | J | XJ64 | 1332 | J | 13 | X | IN | LND | 1332 |  | URMA | 2011-05-10 | E-17-04-05 |  | 2012-03-20 |  | 2012-08-15 | 2011-07-25 |  |  |  |  |  |  |  |  |
| XJ621332 |  | CA13 R.G.Compressor - Termin Multicore Cables | 40d | 2012-05-26 | 2012-07-13 | XJ521332 FF+10d, XJ321332 |  |  | 21.5d | 82d |  |  | Termination Field [705 mhr]; Termination field [705 h] | 70,500 |  | 705,00 |  |  | XJ621332 | 705 | 0 |  | 934 | 13 | 200 | 200 | C | LND | X | J | XJ62 | 1332 | J | 13 | X | IN | LND | 1332 |  | URMA | 2011-05-20 | E-17-01-01 |  | 2012-03-10 |  | 2012-06-16 | 2011-11-01 |  |  |  |  |  |  |  |  |
| XJ521332 |  | CA13 R.G.Compressor - Pulling Multicore Cables | 20d | 2012-06-07 | 2012-07-02 | XJ321332 SS+20d, XJ525103 SS+12d, XE500C01, XE401332, XJ521301 SS, XJ525401 SS+18d, XJ525102 SS+15d, XJ525104 SS+10d |  |  | 21.5d | 0d |  | TB26 - V - Construct-Winter partly * | Multicore cables [3900 m]; Pull multicore cables [1950 h] | 78,000 |  | 1950,00 |  |  | XJ521332 | 1950 | 0 |  | 934 | 13 | 200 | 200 | C | LND | X | J | XJ52 | 1332 | J | 13 | X | IN | LND | 1332 |  | URMA | 2011-05-20 | E-17-01-01 |  | 2012-03-10 |  | 2012-06-16 | 2011-11-01 | m | 2850 | 2011-09-30 | 2011-11-16 |  |  | to be checked |  |
| XJ801332 |  | CA13 R.G.Compressor - Inspections/ Mech. Acceptance/ Loop Checks | 60d | 2012-08-25 | 2012-11-03 | X3J120, EJ801332 (other project), XJ391332 SS+10d, X030410030, XJ641332 FF+15d, XJ701332 SS, XE601332, XJ621332 FF+15d |  |  | -60.5d | 35d |  |  | Loop Checks [260 pcs]; Loop checks [1300 h] | 52,000 |  | 1300,00 |  |  | XJ801332 | 1300 | 0 |  | 934 | 13 | 200 | 200 | C | LND | X | J | XJ80 | 1332 | J | 13 | X | LT | LND | 1332 |  | URMA | 2011-06-10 | E-17-02-01 |  | 2012-04-30 |  | 2012-08-18 | 2012-03-01 |  |  |  |  |  |  |  | 2012-08-18 |

Notes:
- XJ321332: Current Status: 20110727 (O.Siegel): die inst

| ID | WBS | Activity | Type | Duration | Start | Finish | Predecessors | Complete | Planned start | Planned finish | Total float | Free float | Constraint | Calendar | Resources | Cost | Actual cost | TB26 Ressource Budget | UDF_SAVE ACT ID | UDF_BUDGETED LABOR UNIT | UDF_ACTUAL LABOR UNIT | Department | Constr. Area | PMT-Area | PMT-Schedule Org | PMT-Phase | PMT-Respons. | WBS Phase | WBS Discipline | WBS Type of Work | WBS Objects | Russia WBS Discipline (Russia) | Russia Construction Area | Russia WBS Phase | IMS | UPT | Russia WBS Objects | Subcontractor | UDF_CONTRACT FINISH DATE | UDF_CONTRACT ITEM | Type of Work | Inquiry/Order No | Zeigen/n. Zeigen | Comments | Civil item | UDF_CONTRACT DATE PENALIZED | UDF_PENALIZED START | UDF_PENALIZED FINISH | UDF_Concrete | UDF_CHECK CRITICAL PATH | UDF_BASELINE DEVELOPMENT | Check ResLoading |
| --- | --- | --- | --- | --- | --- | --- | --- | --- | --- | --- | --- | --- | --- | --- | --- | --- | --- | --- | --- | --- | --- | --- | --- | --- | --- | --- | --- | --- | --- | --- | --- | --- | --- | --- | --- | --- | --- | --- | --- | --- | --- | --- | --- | --- | --- | --- | --- | --- | --- | --- | --- | --- |
|  | W | **Painting** |  |  | 2012-02-27 | 2012-04-25 |  |  |  |  |  |  |  |  |  |  |  |  |  |  |  |  |  |  |  |  |  |  |  |  |  |  |  |  |  |  |  |  |  |  |  |  |  |  |  |  |  |  |  |  |  |  |
| XW501332 |  | CA13 R.G.Compressor - Surf.Protection Piping |  | 50d | 2012-02-27 | 2012-04-25 | XR801332 FF+20d, XR201332 SS |  |  |  | 1d | 0d |  |  | Piping painting [331 sqm]; Piping painting [828 h] | 434.58 |  | 828,00 | XW501332 | 828 | 0 | 934 | 13 | 200 | 200 | C | LND | X | W | XW50 | 1332 | W | 13 | X | PA | LND | 1332 | VNZM |  |  |  |  |  |  |  |  |  |  |  |  |  |  |
|  | V | **Insulation** |  |  | 2012-05-10 | 2012-08-23 |  |  |  |  |  |  |  |  |  |  |  |  |  |  |  |  |  |  |  |  |  |  |  |  |  |  |  |  |  |  |  |  |  |  |  |  |  |  |  |  |  |  |  |  |  |  |
| XV301332 |  | CA13 R.G.Compressor - Insulation Equipment |  | 70d | 2012-05-10 | 2012-07-31 | K-22201A/B, XE801332 SS+20d |  |  |  | 1d | 0d |  |  | Equipment insulation [100 sqm]; Equipment insulation [1250 h] | 310.42 |  | 1250,00 | XV301332 | 1250 | 0 | 934 | 13 |  |  |  | LND | X | V | XV30 | 1332 | V | 13 | X | INS | LND | 1332 | VNZM | 2012-03-30 | E-13-03 |  |  |  |  |  |  |  |  |  |  |  |  |
| XV501332 |  | CA13 R.G.Compressor - Insulation Piping |  | 70d | 2012-06-02 | 2012-08-23 | XE801332 FF+20d, XV301332 FF+20d, XR601332 SS |  |  |  | 1d | 96.5d |  |  | Piping insulation [300 sqm]; Piping insulation [2250 h] | 1,241.67 |  | 2250,00 | XV501332 | 2250 | 0 | 934 | 13 | 200 | 200 | C | LND | X | V | XV50 | 1332 | V | 13 | X | INS | LND | 1332 | VNZM | 2012-04-30 | E-13-01 |  |  |  |  |  |  |  |  |  |  |  |  |
|  | 33 | **CA13 - Bleed Booster Compressor** |  |  |  |  |  |  |  |  |  |  |  |  |  |  |  |  |  |  |  |  |  |  |  |  |  |  |  |  |  |  |  |  |  |  |  |  |  |  |  |  |  |  |  |  |  |  |  |  |  |  |
|  | 14 | **CA14 - Flare** |  |  | 2008-09-24 | 2012-10-23 |  |  |  |  |  |  |  |  |  |  |  |  |  |  |  |  |  |  |  |  |  |  |  |  |  |  |  |  |  |  |  |  |  |  |  |  |  |  |  |  |  |  |  |  |  |  |
|  | 00 | **CA14 - General** |  |  | 2012-09-18 | 2012-10-23 |  |  |  |  |  |  |  |  |  |  |  |  |  |  |  |  |  |  |  |  |  |  |  |  |  |  |  |  |  |  |  |  |  |  |  |  |  |  |  |  |  |  |  |  |  |  |
|  | 0B | **General Activities** |  |  | 2012-09-18 | 2012-10-23 |  |  |  |  |  |  |  |  |  |  |  |  |  |  |  |  |  |  |  |  |  |  |  |  |  |  |  |  |  |  |  |  |  |  |  |  |  |  |  |  |  |  |  |  |  |  |
| X0101410 |  | CA14 General - Construction Completion | milestone | 0d | 2012-09-18 | 2012-09-18 | XN401410, XE501410, XE801410, XN601130, XE501130, XJ541130, XC601410, XC191410, XE601410, XJ641130, XN601410, XE701410, XE701130, FL-24401, XB101130, XE801130, XN301410, XR401410, XE911411, XE601130, XJ641410, XJ541410, XR401130, XE911131, XJ621130, XJ391410, XJ391130, XJ391510, XJ391610 |  |  |  | -79.5d | 32d |  | TB26 - 2 - Manuf and Delivy |  |  |  |  | X0101410 | 0 | 0 | 934 | 14 | 200 | 200 | C | LND | X | 0B | X010 | 1400 | 0 | 14 | X | MC | LND | 1400 |  |  |  | XNK | 2DD0330 | FL |  |  |  |  |  |  |  |  |  |
| X0101400 |  | CA14 General - Mechanical Completion | milestone | 0d | 2012-10-23 | 2012-10-23 | XE601410, XV301410, XV501410, XE911411, XE701130, XJ801130, XV501130, P3R01S (other project), XE911131, X0101410, XE601130, XE701410, XJ801410 |  |  |  | -59.5d | 67d |  | TB26 - 2 - Manuf and Delivy |  |  |  |  | X0101400 | 0 | 0 | 934 | 14 | 200 | 200 | C | LND | X | 0B | X010 | 1400 | 0 | 14 | X | MC | LND | 1400 |  |  |  | XNK | 2DD0330 | FL |  |  |  |  |  |  |  |  |  |
|  | 04 | **CA14 - Auxiliary Structures** |  |  |  |  |  |  |  |  |  |  |  |  |  |  |  |  |  |  |  |  |  |  |  |  |  |  |  |  |  |  |  |  |  |  |  |  |  |  |  |  |  |  |  |  |  |  |  |  |  |  |
|  | 10 | **CA14 - Flare Package** |  |  | 2008-09-24 | 2012-10-23 |  |  |  |  |  |  |  |  |  |  |  |  |  |  |  |  |  |  |  |  |  |  |  |  |  |  |  |  |  |  |  |  |  |  |  |  |  |  |  |  |  |  |  |  |  |  |
|  | 0B | **General Activities** |  |  | 2011-11-19 | 2011-11-19 |  |  |  |  |  |  |  |  |  |  |  |  |  |  |  |  |  |  |  |  |  |  |  |  |  |  |  |  |  |  |  |  |  |  |  |  |  |  |  |  |  |  |  |  |  |  |
| A1010280 |  | CA14 Flare Pa - Ready for Install Flare Tower Frames | milestone | 0d | 2011-11-19 | 2011-11-19 | XN201410 FF |  |  |  | -81d | 0d | as late as possible |  |  |  |  |  | A1010280 | 0 | 0 | 934 | 14 | 200 | 200 | C | LND | X | 0B | X000 | 1410 | 0 | 12 | X | EQ | LND | 1201 |  |  |  | XNK |  |  |  |  |  |  |  |  |  |  |  |
|  | C | **Civil Work** |  |  | 2008-09-24 | 2012-06-19 |  |  |  |  |  |  |  |  |  |  |  |  |  |  |  |  |  |  |  |  |  |  |  |  |  |  |  |  |  |  |  |  |  |  |  |  |  |  |  |  |  |  |  |  |  |  |
| XC111410 |  | CA14 Flare Pa - Excavation&Surface Prep U/I/O |  | 294d | 2008-09-24 A | 2009-09-30 A | XC115301 SS | 100% |  |  |  |  |  |  |  |  |  |  | XC111410 | 0 | 0 | 934 | 14 | 200 | 200 | C | UIO | X | C | XC11 | 1410 | C | 14 | X | CW | LND | 1410 | MO11 |  |  |  |  |  |  |  |  |  |  |  |  |  |  |
| XC11141005 |  | CA14 Flare Pa - Excavation |  | 12d | 2011-04-11 A | 2011-04-23 A | XC11560105 FS+220d | 100% |  |  |  |  |  |  | Excavation [4000 cbm]; Excavation [2000 h] | 160,000 | 160,000 | 2000,00 | XC11141005 | 2000 | 2000 | 934 | 14 | 200 | 200 | C | MO02 | X | C | XC11 | 1410 | C | 10 | X | P | LND | 1010 | MO11 |  |  |  | 999 |  |  |  |  |  |  |  |  |  |  |
| XC11141010 |  | CA14 Flare Pa - SubBase (Gravel/Geogrid) for Concrete |  | 24d | 2011-04-23 A | 2011-05-24 A | XC11141005 FS+5d | 100% | 2011-04-23 | 2011-05-23 |  |  |  |  | Sub Base for Concrete/Paving&Roads (Gravel) [3000 cbm]; Subbase for Concrete [3000 h] | 300,000 | 100,000 | 3000,00 | XC11141010 | 3000 | 3000 | 934 | 14 | 200 | 200 | C | MO02 | X | C | XC11 | 1410 | C | 10 | X | P | LND | 1010 | MO11 |  |  |  | 999 |  |  |  |  |  |  |  |  |  |  |
| XC151410 |  | CA14 Flare Pa - Piling |  | 10d | 2011-05-03 A | 2011-05-16 A | XC11141005, XC151010, IMS-C-000010 FF, F2910, EC151130 (other project) FS+10d, EC151410 (other project) FS+10d | 100% | 2011-05-03 | 2011-05-14 |  |  |  |  | Piles driven [159 pcs]; Piles driven [1192.5 h] | 47,700 | 62,700 | 1192,50 | XC151410 | 1192,5 | 1192,5 | 934 | 14 | 200 | 200 | C | MO02 | X | C | XC15 | 1400 | C | 14 | X | P | LND | 1410 | MO11 |  |  |  | 2DD0330 |  |  |  |  |  |  |  |  |  |  |
| XC201410 |  | CA14 Flare Package - Concrete Works Foundations |  | 46d | 2011-05-25 A | 2011-07-08 A | EC45141015 (other project), EC45141005 (other project), XC151410, XC11141010 FS-10d, EC281410 (other project) FS+10d | 100% | 2011-05-25 | 2011-07-18 |  |  |  |  | Concrete works [720 cbm]; Concrete works [21600 h] | 1,533.61 |  | 21600,00 | XC201410 | 21600 | 20550 | 934 | 14 | 200 | 200 | C | CiC | X | C | XC20 | 1410 | C | 14 | X | mis | LND | 1410 | MO11 |  |  |  | 2DD0330 | FL | Templete wird benцtigt, dieser kommt mit der Fakellieferung | x | P | 2011-06-30 | 2011-06-30 |  |  |  |  |
| XC301410 |  | CA14 Flare Package - UG Installation (incl. Precast Manholes) |  | 50d | 2012-03-02 | 2012-04-30 | XC205301 FF+20d, XC201410 SS+27d, P3R02S1 (other project), XC205104 FF+20d, P3R02AS1 (other project), P3R02S1 (other project) FF, XC310C00, P3R02BS (other project), XC300C00, ER441200 (other project), P3S08S (other project) FF+30d |  |  |  | 10d | 0d | start on or after 2012-03-02 |  | Cast Iron U/G Piping [40 m]; Concrete Manholes [17 pcs]; Floor Drains / Catch Basins [2 pcs]; Fire water hydrants/monitors [1 pcs]; FRP U/G Piping [20 m]; Cast iron U/G piping [800 h]; concrete manholes [4675 h]; floor drains / catch basins [50 h]; fire water hydrants/ monitors [62.5 h]; FRP U/G piping [250 h] | 213,750.38 |  | 5837,50 | XC301410 | 5837,5 | 0 | 934 | 14 | 200 | 200 | C | CiC | X | C | XC30 | 1410 | C | 14 | X | UG | LND | 1410 |  |  |  |  | 2DD0330 |  |  |  |  |  |  | 1 | XC301410 | XC301410 | UG |
| XC191410 |  | CA14 Flare Package - Backfill |  | 45d | 2012-04-02 | 2012-05-25 | XC911410 FS+20d, XC915301 FF+20d, XC915104 FF+20d, XC301410 FF+20d |  |  |  | 10d | 0d |  | TB26 - T - Construct-Winter-3 (Dec/Jan/Feb free) * | Backfill & Compaction [2000 cbm]; Backfill & Compaction [3000 h] | 180,000 |  | 3000,00 | XC191410 | 3000 | 0 | 934 | 14 | 200 | 200 | C | CiC | X | C | XC19 | 1410 | C | 14 | X | UG | LND | 1410 | MO11 |  |  |  |  |  |  |  |  |  |  |  |  |  |  |
| XC601410 |  | CA14 Flare Package - Paving |  | 35d | 2012-05-08 | 2012-06-19 | XC191410 SS+20d, XC191410 FF+20d |  |  |  | 10d | 77.5d |  |  | Concrete paved areas & concrete Roads [1200 sqm]; Gravel [46800 sqm]; Concrete paved areas & concrete roads [4500 h]; Gravel [2340 h] | 111,016.61 |  | 6840,00 | XC601410 | 6840 | 0 | 934 | 14 | 200 | 200 | C | CiC | X | C | XC60 | 1410 | C | 14 | X | PV | LND | 1410 | MO11 |  |  |  |  |  |  |  |  |  |  | 1 |  |  |  |

Notes:
- XW501332: P3 Activity Log Info: Clarification Surface / Protection during Prefab
- XC111410: P3 Activity Log Info: incl. Dewatering/Drainage
- XC11141005: Current Status: 12.01.2011 (O.Siegel): nach Rьcksprache mit MO11 am 11 und 12-Jan-11 wrude / der Starttermin auf den 04-Apr-2011 gelegt.
- XC191410: Scope: 04.03.2011: die Ressource wurden wie folgt an den CPM / Report Daten angepasst: MC2B von 750 auf 2000; LC2B von 1125 auf / 3000.

| ID | WBS | Activity | Type | Duration | Start | Finish | Predecessors | Complete | Planned start | Planned finish | Total float | Free float | Constraint | Calendar | Resources | Cost | Actual cost | TB26 Ressource Budget | UDF_SAVE ACT ID | UDF_CHECK BASELINE | UDF_BUDGETED LABOR UNIT | UDF_ACTUAL LABOR UNIT | Department | Type of Work | Constr. Area | PMT-Area | PMT-Schedule Org | PMT-Phase | PMT-Respons. | Zeigen/n. Zeigen | WBS Phase | WBS Discipline | WBS Type of Work | WBS Objects | Russia WBS Discipline (Russia) | Russia Construction Area | Russia WBS Phase | IMS | UPT | Russia WBS Objects | UDF_SELECT | UDF_CONTRACT START DATE | UDF_CONTRACT FINISH DATE | UDF_CONTRACT ITEM | TB26 Semantics | UDF_Vendor Representatives | UDF_CONTRACT FINISH DATE REV1 | UDF_CONTRACT START DATE REV1 | UDF_SELECT UPDATE PROGRESS | Inquiry/Order No | Subcontractor | WEIGHT | UDF_LEVEL | UDF_PO No | UDF_TAG No | UDF_Object No | UDF_DELIVERY DATE PO | UDF_DELIVERY DATE DISPATCH PLANNED | UDF_DELIVERY DATE TO SITE PLANNED | UDF_DELIVERY DATE SITE NEED DATE | UDF_PACKAGE | UDF_SUPPLIER | UDF_PLANNED START | UDF_PLANNED FINISH | UDF_CONTRACT INDICATOR | TB26 Material Res Values | UDF_ELECTRICAL START | UDF_ELECTRICAL FINISH | UDF_COMMENTS_0827 | Filter | geplanter Start | geplantes Ende |
| --- | --- | --- | --- | --- | --- | --- | --- | --- | --- | --- | --- | --- | --- | --- | --- | --- | --- | --- | --- | --- | --- | --- | --- | --- | --- | --- | --- | --- | --- | --- | --- | --- | --- | --- | --- | --- | --- | --- | --- | --- | --- | --- | --- | --- | --- | --- | --- | --- | --- | --- | --- | --- | --- | --- | --- | --- | --- | --- | --- | --- | --- | --- | --- | --- | --- | --- | --- | --- | --- | --- | --- | --- |
|  | N | **Structural Steel** |  |  | 2011-05-23 | 2011-10-26 |  |  |  |  |  |  |  |  |  |  |  |  |  |  |  |  |  |  |  |  |  |  |  |  |  |  |  |  |  |  |  |  |  |  |  |  |  |  |  |  |  |  |  |  |  |  |  |  |  |  |  |  |  |  |  |  |  |  |  |  |  |  |  |  |  |  |
| XN701400 |  | CA14 Flare Package - KMD Assy Drawings | milestone | 0d | 2011-05-23 A | 2011-05-23 A |  | 100% |  |  |  |  | finish on 2011-05-23 | TB26 - V - Construct-Winter partly * |  |  |  | 22t | XN701400 | x | 0 | 0 | 934 | XNK | 14 | 200 | 200 | C | LND | KMD | X | N | XN05 | 1410 | N | 14 | X | SS | LND | 1410 |  |  |  |  |  |  |  |  |  |  |  |  |  |  |  |  |  |  |  |  |  |  |  |  |  |  |  |  |  |  |  |  |
| XN711400 |  | CA14 Flare Package - Steel Deliveries | milestone | 0d | 2011-07-01 A | 2011-07-01 A |  | 100% |  |  |  |  | finish on 2011-07-01 | TB26 - 3 - Construction Normal 7days * CA17 |  |  |  | 22t | XN711400 |  | 0 | 0 | 934 | XNK | 14 | 200 | 200 | C | LND | SD | X | N | XN06 | 1410 | N | 14 | X | SS | LND | 1410 |  |  |  |  |  |  |  |  |  |  |  |  |  |  |  |  |  |  |  |  |  |  |  |  |  |  |  |  |  |  |  |  |
| XN201410 |  | CA14 Flare Package - Pre Assembly Steel Str. Frames (by Flare Contractor) |  | 45d | 2011-09-05 | 2011-10-26 | P3N02ЬN (other project), XR500C00 FS+15d |  |  |  | -81d | 0d | start on or after 2011-09-05 |  | Piperacks, Main Structures [6 t]; Piperacks, Main structures [255 h] | 1,448.61 |  | 255,00 | XN201410 |  | 255 | 0 | 934 | XNK | 14 | 200 | 200 | C | LND | FL | X | N | XN20 | 1410 | N | 14 | X | SS | LND | 1410 | 110908 | 2011-05-01 | 2011-06-30 | E-04-01-08 | t | 025 | 2011-12-01 | 2011-08-22 | 27.8. | 2DD0330 | SEM |  |  |  |  |  |  |  |  |  |  |  |  |  |  |  |  |  |  |  |  |  |
| XN301410 |  | CA14 Flare Package - Pre Assembly Platforms (by Flare Contractor) |  | 40d | 2011-09-10 | 2011-10-26 | XN201410 FF, P3N02ЬN (other project), XN711400 FS+10d, XN701400 |  |  |  | 44d | 0d |  |  | Ladders & platforms [5 t]; Ladders & platforms [500 h] | 1,448.61 |  | 500,00 | XN301410 |  | 500 | 0 | 934 | XNK | 14 | 200 | 200 | C | LND | FL | X | N | XN30 | 1410 | N | 14 | X | SS | LND | 1410 | 110908 | 2011-05-01 | 2011-06-30 | E-04-01-08 | t |  | 2011-12-01 | 2011-08-22 |  | 2DD0330 | SEM |  |  |  |  |  |  |  |  |  |  |  |  |  |  |  |  |  |  |  |  |  |
| XN401410 |  | CA14 Flare Package - Pre Assembly Railings,Ladders,etc. (by Flare Contractor) |  | 40d | 2011-09-10 | 2011-10-26 | XN301410 FF, XN201410 FF |  |  |  | 44d | 0d |  |  | Ladders & platforms [2 t]; Ladders & platforms [200 h] | 206.94 |  | 200,00 | XN401410 |  | 200 | 0 | 934 | XNK | 14 | 200 | 200 | C | LND | FL | X | N | XN40 | 1410 | N | 14 | X | SS | LND | 1410 | 110908 | 2011-05-01 | 2011-06-30 | E-04-01-08 |  |  | 2011-12-01 | 2011-08-22 |  |  | SEM |  |  |  |  |  |  |  |  |  |  |  |  |  |  |  |  |  |  |  |  |  |
| XN601410 |  | CA14 Flare Package - Pre Assembly Gratings (by Flare Contractor) |  | 40d | 2011-09-10 | 2011-10-26 | XN401410 FF, PN691410 (other project) |  |  |  | 64d | 20d |  |  | Grating [100 sqm]; Grating [375 h] | 8,019.1 |  | 375,00 | XN601410 |  | 375 | 0 | 934 | XNK | 14 | 200 | 200 | C | LND | FL | X | N | XN60 | 1410 | N | 14 | X | SS | LND | 1410 | 110908 |  |  | E-04-01-08 |  |  | 2011-12-01 | 2011-08-22 |  |  | SEM |  |  |  |  |  |  |  |  |  |  |  |  |  |  |  |  |  |  |  |  |  |
|  | H | **HVAC** |  |  |  |  |  |  |  |  |  |  |  |  |  |  |  |  |  |  |  |  |  |  |  |  |  |  |  |  |  |  |  |  |  |  |  |  |  |  |  |  |  |  |  |  |  |  |  |  |  |  |  |  |  |  |  |  |  |  |  |  |  |  |  |  |  |  |  |  |  |  |
|  | U | **Package Units** |  |  |  |  |  |  |  |  |  |  |  |  |  |  |  |  |  |  |  |  |  |  |  |  |  |  |  |  |  |  |  |  |  |  |  |  |  |  |  |  |  |  |  |  |  |  |  |  |  |  |  |  |  |  |  |  |  |  |  |  |  |  |  |  |  |  |  |  |  |  |
|  | B | **Mechanical - Stationary Equipment** |  |  | 2011-10-21 | 2011-12-10 |  |  |  |  |  |  |  |  |  |  |  |  |  |  |  |  |  |  |  |  |  |  |  |  |  |  |  |  |  |  |  |  |  |  |  |  |  |  |  |  |  |  |  |  |  |  |  |  |  |  |  |  |  |  |  |  |  |  |  |  |  |  |  |  |  |  |
| XB30141005 |  | CA14 Flare Package - Crane Relocation / Boom Extension |  | 5d | 2011-10-21 | 2011-10-26 | XN201410 FF |  |  |  | -81d | 0d | as late as possible |  |  |  |  |  | XB30141005 |  | 0 | 0 | 934 | XBB | 14 | 200 | 200 | C | LND |  | X | B | XB30 | 1410 | B | 12 | X | HL | LND | 1201 | 110908 | 2011-04-10 | 2011-07-30 | E-08-01-11 |  |  |  |  |  |  |  |  |  |  |  |  |  |  |  |  |  |  |  |  |  |  |  |  |  |  |  |  |
| FL-24401 |  | FLARE PACKAGE |  | 30d | 2011-10-27 | 2011-12-01 | XB30141005 |  |  |  | -81d | 0d |  |  | Flare [1500 mhr]; Flare [1500 h] | 150,000 |  | 1500,00 | FL-24401 |  | 1500 | 0 |  |  | 14 |  |  |  |  | EQ | X | B |  | 1410 |  |  |  |  |  |  | 110908 |  |  | E-04-01-08 |  | 025 | 2011-12-01 | 2011-08-22 |  |  | SEM | 200000 | concrete +0.00 | 2 DD 8470 | FL-24401 | SK1410 | 2011-03-15 | 2011-03-15 | 2011-04-15 | 2011-05-10 | A18 FLARE PACKAGE | ITAS |  |  |  |  |  |  |  |  |  |  |
| XB001410 |  | CA14 Flare Package - Heavy Lift Flare pre assembled Tower Frames |  | 10d | 2011-11-21 | 2011-12-01 | A1010280, XC201010, XB30141005, FL-24401 FF, P3A01S5 (other project), XN201410, ER291400 (other project) FS+40d, XC201410, P3A18S (other project), P3S10S (other project) |  |  |  | -81d | 0d |  |  | Flare [1000 mhr]; Flare [1000 h] | 100,000 |  | 1000,00 | XB001410 |  | 1000 | 0 | 934 | XBB | 14 | 200 | 200 | C | LND | FL | X | B | XB10 | 1410 | B | 14 | X | EQ | LND | 1410 | 110908 | 2011-04-10 | 2011-07-30 | E-08-01-11 |  |  |  |  |  | 2DD0330 |  |  |  |  |  |  |  |  |  |  |  |  |  |  |  |  |  |  |  |  |  |  |
| XB30141010 |  | CA14 Flare Package - Crane Demobilisation |  | 8d | 2011-12-02 | 2011-12-10 | XB001410 |  |  |  | -29d | 7d |  |  |  |  |  |  | XB30141010 |  | 0 | 0 | 934 | XBB | 14 | 200 | 200 | C | LND |  | X | B | XB30 | 1410 | B | 12 | X | HL | LND | 1201 | 110908 | 2011-04-10 | 2011-07-30 | E-08-01-11 |  |  |  |  |  |  |  |  |  |  |  |  |  |  |  |  |  |  |  |  |  |  |  |  |  |  |  |  |
|  | M | **Mechanical - Rotating Equipment** |  |  |  |  |  |  |  |  |  |  |  |  |  |  |  |  |  |  |  |  |  |  |  |  |  |  |  |  |  |  |  |  |  |  |  |  |  |  |  |  |  |  |  |  |  |  |  |  |  |  |  |  |  |  |  |  |  |  |  |  |  |  |  |  |  |  |  |  |  |  |
|  | R | **Piping** |  |  | 2011-10-04 | 2012-01-12 |  |  |  |  |  |  |  |  |  |  |  |  |  |  |  |  |  |  |  |  |  |  |  |  |  |  |  |  |  |  |  |  |  |  |  |  |  |  |  |  |  |  |  |  |  |  |  |  |  |  |  |  |  |  |  |  |  |  |  |  |  |  |  |  |  |  |
| XR201410 |  | CA14 Flare Package - Piping Prefabrication |  | 20d | 2011-10-04 | 2011-10-26 | ER491410 (other project), IMS-C-000180 FF, XR500C00 FS+15d |  |  |  | 44d | 0d | as late as possible |  | A/G piping prefabrication [430 Fpi]; A/G Piping (Prefab) [1612.5 h] | 3,344.37 |  | 1612,50 | XR201410 |  | 1612,5 | 0 | 934 |  | 14 | 200 | 200 | C | LND | FL | X | R | XR20 | 1410 | R | 14 | X | PRP | LND | 1410 |  |  |  |  |  |  |  |  |  |  |  |  |  |  |  |  |  |  |  |  |  |  |  |  |  |  |  |  |  |  |  |  |
| XR401410 |  | CA14 Flare Package - Piping Installation |  | 40d | 2011-10-27 | 2011-12-13 | P3S10S (other project), XN601410 FF+20d, XR201410, XN401410 |  |  |  | 44d | 0d |  |  | A/G piping field installation [525 Fpi]; A/G Piping (Field) [3281.25 h] | 11,884.54 |  | 3281,25 | XR401410 |  | 3281,25 | 0 | 934 |  | 14 | 200 | 200 | C | LND | FL | X | R | XR40 | 1410 | R | 14 | X | PI | LND | 1410 | 110908 | 2011-06-30 | 2011-09-30 | E-06-03-05 |  |  |  |  |  | 2DD0330 |  |  |  |  |  |  |  |  |  |  |  |  | 2011-09-10 |  |  |  |  |  |  |  |  |  |
| XR601410 |  | CA14 Flare Package - Piping Pressure Tests |  | 20d | 2011-12-02 | 2011-12-24 | XR401410 FF+10d |  |  |  | 101d | 0d |  |  |  |  |  | 112 | XR601410 |  | 0 | 0 | 934 |  | 14 | 200 | 200 | C | LND | FL | X | R | XR60 | 1410 | R | 14 | X | HY | LND | 1410 |  | 2011-06-30 | 2011-09-30 | E-06-03-05 |  |  |  |  |  | 2DD0330 |  |  |  |  |  |  |  |  |  |  |  |  |  |  |  |  |  |  |  |  |  |  |
| XR801410 |  | CA14 Flare Package - Piping Reinstatement |  | 20d | 2011-12-14 | 2012-01-12 | XR601410 FF+10d, IMS-C-000360 FF |  |  |  | 101d | 0d |  |  |  |  |  | 56 | XR801410 |  | 0 | 0 | 934 |  | 14 | 200 | 200 | C | LND | FL | X | R | XR80 | 1410 | R | 14 | X | PI | LND | 1410 |  | 2011-06-30 | 2011-09-30 | E-06-03-05 |  |  |  |  |  |  |  |  |  |  |  |  |  |  |  |  |  |  |  | 2011-12-12 |  |  |  |  |  |  |  |  |
|  | E | **Electrical** |  |  | 2011-07-01 | 2012-09-18 |  |  |  |  |  |  |  |  |  |  |  |  |  |  |  |  |  |  |  |  |  |  |  |  |  |  |  |  |  |  |  |  |  |  |  |  |  |  |  |  |  |  |  |  |  |  |  |  |  |  |  |  |  |  |  |  |  |  |  |  |  |  |  |  |  |  |
| XC911410 |  | CA14 Flare Package - Install Earthing System_CIVIL |  | 5d | 2011-07-01 A | 2011-07-07 A | EE901010 (other project), XC201410 FF, EE901410 (other project) | 100% | 2011-07-13 | 2011-07-18 |  |  |  |  | Grounding & Lightning [100 pcs]; Grounding & Lightning [1125 h] | 45,000 | 45,000 | 1125,00 | XC911410 |  | 1125 | 0 | 934 |  | 14 | 200 | 200 | C | LND | FL | X | C | XE91 | 1410 | C | 14 | X | EA | LND | 1410 |  |  |  |  |  |  |  |  |  |  | MO11 |  |  |  |  |  |  |  |  |  |  |  |  |  |  |  |  |  |  |  |  |  |
| XE401410 |  | CA14 Flare Packa - Install Cable Trays |  | 40d | 2011-11-21 | 2012-02-22 | XR401410 SS+20d, XN301410 SS+10d |  |  |  | 24d | 0d |  | TB26 - V - Construct-Winter partly * | Cable trays/conduits [120 m]; Cable trays [360 h] | 14,400 |  | 360,00 | XE401410 | x | 360 | 0 | 934 |  | 14 | 200 | 200 | C | LND |  | X | E | XE40 | 1410 | E | 14 | X | EL | LND | 1410 | 110908 |  |  |  | m |  |  |  |  |  | URMA |  |  |  |  |  |  |  |  |  |  |  |  |  | UDF_G3 | 350 | 2011-10-17 | 2011-12-21 | to be checked |  |  |  |
| XE911411 |  | CA14 Flare Package - Install Earthing System_E/I |  | 18d | 2011-12-02 | 2011-12-22 | FL-24401 |  |  |  | 153d | 220.5d |  |  |  |  |  | 115 | XE911411 |  | 0 | 0 | 934 |  | 14 | 200 | 200 | C | LND | FL | X | E | XE91 | 1410 | E | 14 | X | EA | LND | 1410 |  |  |  |  |  |  |  |  |  |  | URMA |  |  |  |  |  |  |  |  |  |  |  |  |  | UDF_G3 |  |  |  |  |  |  |  |
| XE801410 |  | CA14 Flare Packa - Install Heat Tracing |  | 40d | 2011-12-14 | 2012-03-14 | P3E19S (other project), XW501410 FF+20d, E3E1950 (other project), XR401410, XR601410 FF+10d |  |  |  | 87d | 0d |  | TB26 - V - Construct-Winter partly * | Electrical Heat Tracing [1000 m]; Electrical heat tracing [500 h] | 20,000 |  | 500,00 | XE801410 |  | 500 | 0 | 934 |  | 14 | 200 | 200 | C | LND |  | X | E | XE80 | 1410 | E | 14 | X | HT | LND | 1410 |  | 2011-06-20 | 2012-03-20 | E-16-04-01 |  | 005 | 2012-06-30 | 2011-09-15 |  |  | URMA |  |  |  |  |  |  |  |  |  |  |  |  |  | UDF_G3 |  |  |  | to be checked |  |  |  |
| XE341410 |  | CA14 Flare Packa - Install Local Operation Panels |  | 10d | 2012-02-27 | 2012-03-12 | XE401410, XR401410 SS+20d, FL-24401 |  |  |  | 79d | 146.5d |  | TB26 - V - Construct-Winter partly * | Field Panels [2 pcs]; Field panels [40 h] | 1,600 |  | 40,00 | XE341410 |  | 40 | 0 | 934 |  | 14 | 200 | 200 | C | LND |  | X | E | XE34 | 1410 | E | 14 | X | EL | LND | 1410 |  |  |  |  |  |  |  |  |  |  | URMA |  |  |  |  |  |  |  |  |  |  |  |  |  | UDF_G3 |  |  |  |  |  |  |  |
| XE701410 |  | CA14 Flare Packa - Install Lighting &Small Power |  | 30d | 2012-02-29 | 2012-04-10 | XP341610 FS+50d, EE761010 (other project), XE401410 SS+20d, XJ421410, EE761410 (other project) |  |  |  | 67d | 0d |  | TB26 - V - Construct-Winter partly * | Cable Pulling [1200 m]; Lighting illuminates [70 pcs]; Lighting (iluminates) [700 h]; Cable pulling [600 h] | 52,000 |  | 1300,00 | XE701410 |  | 1300 | 0 | 934 |  | 14 | 200 | 200 | C | LND | FL | X | E | XE70 | 1410 | E | 14 | X | EL | LND | 1410 |  | 2011-05-10 | 2012-01-31 | E-16-03-01 |  |  | 2012-05-10 | 2011-08-15 |  |  | URMA |  |  |  |  |  |  |  |  |  |  |  |  |  |  |  |  |  |  | x |  |  |
| XE921410 |  | CA14 Flare Packa - Install Fire Detection System |  | 20d | 2012-04-11 | 2012-05-04 | XJ421410, XE701410 |  |  |  | 279.5d |  |  | TB26 - V - Construct-Winter partly * |  |  |  |  | XE921410 | x | 0 | 0 | 934 |  | 14 | 200 | 200 | C | LND | FL | X | E | XE92 | 1410 | E | 14 | X | FGDS | LND | 1410 |  |  |  |  |  |  |  |  |  |  |  |  |  |  |  |  |  |  |  |  |  |  |  |  |  |  |  |  |  | x | 2012-03-01 | 2012-04-11 |
| XE501410 |  | CA14 Flare Packa - Cable Pulling Electric |  | 60d | 2012-06-22 | 2012-08-31 | P3E15BS (other project), P3E15CS (other project), P3E15AS (other project), XE401410, XE500C01, XE505401 SS+15d, XE505102 SS+10d, XE505103 SS+10d, XE505104 SS+10d, XE505301 SS+8d |  |  |  | -67.5d | 0d |  | TB26 - V - Construct-Winter partly * | Cable Pulling [2400 m]; Cable pulling [1200 h] | 48,000 |  | 1200,00 | XE501410 |  | 1200 | 0 | 934 |  | 14 | 200 | 200 | C | LND |  | X | E | XE50 | 1410 | E | 14 | X | EL | LND | 1410 |  | 2011-05-20 | 2012-02-10 | E-16-01-01 | m |  | 2012-07-01 | 2011-10-01 |  |  | URMA |  |  |  |  |  |  |  |  |  |  |  |  |  | UDF_G3 | 2500 | 2011-12-26 | 2012-04-14 |  |  |  |  |
| XE601410 |  | CA14 Flare Packa - Cable Termination & Testing |  | 30d | 2012-08-14 | 2012-09-18 | XE341410 FF+10d, XE501410 FF+15d, FL-24401 |  |  |  | -67.5d | 0d |  | TB26 - V - Construct-Winter partly * | Cable connecting [30 pcs]; Cable connecting [75 h] | 3,000 |  | 75,00 | XE601410 |  | 75 | 0 | 934 |  | 14 | 200 | 200 | C | LND |  | X | E | XE60 | 1410 | E | 14 | X | ET | LND | 1410 |  | 2011-04-20 | 2011-11-30 | E-16-02-01 |  |  | 2012-08-14 | 2011-12-10 |  |  | URMA |  |  |  |  |  |  |  |  |  |  |  |  |  | UDF_G3 |  |  |  |  |  |  |  |

Notes:
- XN711400: Scope: 09.02.2011: weight: 5 ton - May 5 ton
- XE921410: Scope: GDS - 3 / external sensors

| ID | WBS | Activity | Type | Duration | Start | Finish | Predecessors | Complete | Total float | Free float | Constraint | Calendar | Resources | Cost | TB26 Ressource Budget | UDF_CONTRACT INDICATOR | UDF_SAVE ACT ID | UDF_BUDGETED LABOR UNIT | UDF_ACTUAL LABOR UNIT | UDF_COMMENTS_0827 | Department | Constr. Area | PMT-Area | PMT-Schedule Org | PMT-Phase | PMT-Respons. | Zeigen/n. Zeigen | WBS Phase | WBS Discipline | WBS Type of Work | WBS Objects | Russia WBS Discipline (Russia) | Russia Construction Area | Russia WBS Phase | IMS | UPT | Russia WBS Objects | Subcontractor | Filter | TB26 Semantics | TB26 Material Res Values | UDF_ELECTRICAL START | UDF_ELECTRICAL FINISH | UDF_CHECK BASELINE | UDF_CONTRACT START DATE | UDF_CONTRACT FINISH DATE | UDF_CONTRACT ITEM | UDF_CONTRACT FINISH DATE REV1 | UDF_CONTRACT START DATE REV1 | UDF_PENALIZED FINISH | Inquiry/Order No | Civil item | UDF_CONTRACT DATE PENALIZED | Type of Work |
| --- | --- | --- | --- | --- | --- | --- | --- | --- | --- | --- | --- | --- | --- | --- | --- | --- | --- | --- | --- | --- | --- | --- | --- | --- | --- | --- | --- | --- | --- | --- | --- | --- | --- | --- | --- | --- | --- | --- | --- | --- | --- | --- | --- | --- | --- | --- | --- | --- | --- | --- | --- | --- | --- | --- |
|  | J | **Instrumentation** |  |  | 2011-12-05 | 2012-10-23 |  |  |  |  |  |  |  |  |  |  |  |  |  |  |  |  |  |  |  |  |  |  |  |  |  |  |  |  |  |  |  |  |  |  |  |  |  |  |  |  |  |  |  |  |  |  |  |  |
| XJ301410 |  | CA14 Flare Package - Install Field Instruments |  | 20d | 2011-12-05 | 2012-01-24 | XR801410 FF, EJ361410 (other project), EJ361010 (other project), XR401410 SS+20d, FL-24401 |  | 72d | 0d |  | TB26 - V - Construct-Winter partly * | Field Instruments [46 pcs]; Install field instruments [253 h] | 10,120 | 253,00 | UDF_G3 | XJ301410 | 253 | 0 | to be checked | 934 | 14 | 200 | 200 | C | LND | FL | X | J | XJ30 | 1410 | J | 14 | X | IN | LND | 1410 | URMA |  |  |  |  |  |  |  |  |  |  |  |  |  |  |  |  |
| XJ321410 |  | CA14 Flare Package - Install Junction Boxes |  | 20d | 2011-12-05 | 2012-01-24 | XN601410, EJ321010 (other project), XR401410 SS+30d, EJ321410 (other project), FL-24401 |  | 37d | 0d |  | TB26 - V - Construct-Winter partly * | Junction Boxes/Cabinets/Panels [18 pcs]; Install Junction Boxes/ Cabinets/ Panels [450 h] | 18,000 | 450,00 | UDF_G3 | XJ321410 | 450 | 0 | to be checked | 934 | 14 | 200 | 200 | C | LND | FL | X | J | XJ32 | 1410 | J | 14 | X | IN | LND | 1410 | URMA |  |  |  |  |  |  |  |  |  |  |  |  |  |  |  |  |
| XJ421410 |  | CA14 Flare Package - Install Secondary Cable Trays |  | 30d | 2011-12-14 | 2012-02-28 | XR401410 SS+20d, XJ321410 FF+15d, XE401410 FF, FL-24401 |  | 37d | 0d |  | TB26 - V - Construct-Winter partly * | Secondary cable trays [250 m]; Install secondary cable trays [937.5 h] | 37,500 | 937,50 |  | XJ421410 | 937,5 | 0 |  | 934 | 14 | 200 | 200 | C | LND | FL | X | J | XJ42 | 1410 | J | 14 | X | IN | LND | 1410 | URMA | x | m | 220 | 2011-10-17 | 2011-12-21 | x |  |  |  |  |  |  |  |  |  |  |
| XJ701410 |  | CA14 Flare Package - Instrument Tubing |  | 20d | 2012-01-25 | 2012-03-06 | XJ301410 FF+20d, XR401410 |  | 72d | 35d |  | TB26 - V - Construct-Winter partly * |  |  |  |  | XJ701410 | 0 | 0 |  | 934 | 14 | 200 | 200 | C | LND | FL | X | J | XJ70 | 1410 | J | 14 | X | IN | LND | 1410 | URMA |  |  |  |  |  |  |  |  |  |  |  |  |  |  |  |  |
| XJ441410 |  | CA14 Flare Package - Install Conduits to Instrm |  | 20d | 2012-02-29 | 2012-03-28 | XJ321410, XR401410 SS+20d, XE401410, XJ421410, FL-24401 |  | 37d | 0d |  | TB26 - V - Construct-Winter partly * |  |  |  |  | XJ441410 | 0 | 0 |  | 934 | 14 | 200 | 200 | C | LND | FL | X | J | XJ44 | 1410 | J | 14 | X | IN | LND | 1410 | URMA |  |  |  |  |  |  |  |  |  |  |  |  |  |  |  |  |
| XJ391410 |  | CA14 Flare Package - Install Earthing Field Eqpt |  | 20d | 2012-03-29 | 2012-04-21 | XJ301410 FF+20d, XJ421410, XJ441410 |  | 37d | 0d |  | TB26 - V - Construct-Winter partly * |  |  |  |  | XJ391410 | 0 | 0 |  | 934 | 14 | 200 | 200 | C | LND | FL | X | J | XJ39 | 1410 | J | 14 | X | IN | LND | 1410 | URMA |  |  |  |  |  |  |  |  |  |  |  |  |  |  |  |  |
| XJ541410 |  | CA14 Flare Package - Pulling Singlecore Cables |  | 20d | 2012-03-29 | 2012-04-21 | XJ421410, XJ301410 FF+20d, XE500C01, EJ801410 (other project), EJ801010 (other project), XJ441410 SS+20d |  | 42d | 5d |  | TB26 - V - Construct-Winter partly * | Singlecore cables [3600 m]; Pull singlecore cables [2700 h] | 108,000 | 2700,00 |  | XJ541410 | 2700 | 0 |  | 934 | 14 | 200 | 200 | C | LND | FL | X | J | XJ54 | 1410 | J | 14 | X | IN | LND | 1410 | URMA |  | m | 3475 | 2012-04-04 | 2012-04-26 |  |  |  |  |  |  |  |  |  |  |  |
| XJ641410 |  | CA14 Flare Package - Termin Singlecore Cables |  | 20d | 2012-04-23 | 2012-05-17 | XJ301410, XJ541410 FF+15d, XJ701410, XJ321410, XJ391410 |  | 37d | 104.5d |  |  | Termination Field [705 mhr]; Termination field [705 h] | 70,500 | 705,00 |  | XJ641410 | 705 | 0 |  | 934 | 14 | 200 | 200 | C | LND | FL | X | J | XJ64 | 1410 | J | 14 | X | IN | LND | 1410 | URMA |  |  |  |  |  |  |  |  |  |  |  |  |  |  |  |  |
| XJ521410 |  | CA14 Flare Package - Pulling Multicore Cables |  | 20d | 2012-06-07 | 2012-07-02 | XJ525301 SS+8d, XJ321410 SS+20d, XE500C01, XE401410, XJ525401 SS+18d, XJ525102 SS+15d, XJ525103 SS+12d, XJ525104 SS+10d |  | 1.5d | 0d |  | TB26 - V - Construct-Winter partly * | Multicore cables [2000 m]; Pull multicore cables [1000 h] | 40,000 | 1000,00 |  | XJ521410 | 1000 | 0 |  | 934 | 14 | 200 | 200 | C | LND | FL | X | J | XJ52 | 1410 | J | 14 | X | IN | LND | 1410 | URMA |  | m | 1450 | 2012-03-09 | 2012-03-31 |  | 2011-05-20 | 2012-03-10 | E-17-01-01 | 2012-06-16 | 2011-11-01 |  |  |  |  |  |
| XJ621410 |  | CA14 Flare Package - Termin Multicore Cables |  | 20d | 2012-06-26 | 2012-07-19 | XJ521410 FF+15d, XJ321410 |  | 1.5d | 52d |  |  | Termination Field [705 mhr]; Termination field [705 h] | 70,500 | 705,00 |  | XJ621410 | 705 | 0 |  | 934 | 14 | 200 | 200 | C | LND | FL | X | J | XJ62 | 1410 | J | 14 | X | IN | LND | 1410 | URMA |  |  |  |  |  |  | 2011-05-20 | 2012-03-10 | E-17-01-01 | 2012-06-16 | 2011-11-01 |  |  |  |  |  |
| XJ801410 |  | CA14 Flare Package - Inspections/ Mech. Acceptance/ Loop Checks |  | 30d | 2012-09-18 | 2012-10-23 | XJ641410 FF+30d, XJ701410 SS, X3J120, XJ391410 SS+10d, XE601410, XJ621410 FF+30d |  | -50.5d | 0d |  |  | Loop Checks [100 pcs]; Loop checks [500 h] | 20,000 | 500,00 |  | XJ801410 | 500 | 0 |  | 934 | 14 | 200 | 200 | C | LND | FL | X | J | XJ80 | 1410 | J | 14 | X | LT | LND | 1410 | URMA |  |  |  |  |  |  | 2011-06-10 | 2012-04-30 | E-17-02-01 | 2012-08-18 | 2012-03-01 | 2012-08-18 | 2DD0330 |  |  |  |
|  | S | **Safety & Environment** |  |  |  |  |  |  |  |  |  |  |  |  |  |  |  |  |  |  |  |  |  |  |  |  |  |  |  |  |  |  |  |  |  |  |  |  |  |  |  |  |  |  |  |  |  |  |  |  |  |  |  |  |
|  | W | **Painting** |  |  | 2011-12-10 | 2012-02-02 |  |  |  |  |  |  |  |  |  |  |  |  |  |  |  |  |  |  |  |  |  |  |  |  |  |  |  |  |  |  |  |  |  |  |  |  |  |  |  |  |  |  |  |  |  |  |  |  |
| XW501410 |  | CA14 Flare Package - Surf.Protection Piping |  | 40.12d | 2011-12-10 | 2012-02-02 | XR201410 SS, XR801410 FF+18d |  | 103d | 13d |  |  | Piping painting [141 sqm]; Piping painting [353 h] | 564.66 | 353,00 |  | XW501410 | 353 | 0 |  | 934 | 14 | 200 | 200 | C | LND | FL | X | W | XW50 | 1410 | W | 14 | X | PA | LND | 1410 |  |  |  |  |  |  |  |  |  |  |  |  |  |  |  |  |  |
|  | V | **Insulation** |  |  | 2012-02-07 | 2012-04-11 |  |  |  |  |  |  |  |  |  |  |  |  |  |  |  |  |  |  |  |  |  |  |  |  |  |  |  |  |  |  |  |  |  |  |  |  |  |  |  |  |  |  |  |  |  |  |  |  |
| XV301410 |  | CA14 Flare Package - Insulation Equipment |  | 35d | 2012-02-07 | 2012-04-04 | XR401410, XE801410 SS+20d |  | 113d | 0d |  | TB26 - V - Construct-Winter partly * | Equipment insulation [100 sqm]; Equipment insulation [1250 h] | 403.54 | 1250,00 |  | XV301410 | 1250 | 0 |  | 934 | 14 | 200 | 200 | C | LND | FL | X | V | XV30 | 1410 | V | 14 | X | INS | LND | 1410 |  |  |  |  |  |  |  |  | 2012-03-30 | E-13-03 |  |  |  |  |  |  |  |
| XV501410 |  | CA14 Flare Package - Insulation Piping |  | 35d | 2012-02-21 | 2012-04-11 | XR601410 SS+10d, XE801410 FF+20d, XW501410 FF+20d, XV301410 FF+6d |  | 113d | 163.5d |  | TB26 - V - Construct-Winter partly * | Piping insulation [120 sqm]; Piping insulation [900 h] | 1,608.26 | 900,00 |  | XV501410 | 900 | 0 |  | 934 | 14 | 200 | 200 | C | LND | FL | X | V | XV50 | 1410 | V | 14 | X | INS | LND | 1410 |  |  |  |  |  |  |  |  | 2012-04-30 | E-13-01 |  |  |  |  |  |  |  |
|  | 20 | **CA14 - Flare Knockout Drum Section** |  |  | 2011-05-23 | 2012-09-29 |  |  |  |  |  |  |  |  |  |  |  |  |  |  |  |  |  |  |  |  |  |  |  |  |  |  |  |  |  |  |  |  |  |  |  |  |  |  |  |  |  |  |  |  |  |  |  |  |
|  | C | **Civil Work** |  |  | 2011-06-23 | 2011-07-18 |  |  |  |  |  |  |  |  |  |  |  |  |  |  |  |  |  |  |  |  |  |  |  |  |  |  |  |  |  |  |  |  |  |  |  |  |  |  |  |  |  |  |  |  |  |  |  |  |
| XC201130 |  | CA14 FlareKoDrum - Concrete Works Foundations |  | 22d | 2011-06-23 A | 2011-07-18 A | EC45113005 (other project), EC281130 (other project) FS+5d, XC151410 FS+34d, EC45113015 (other project) | 100% |  |  |  |  | Concrete works [80 cbm]; Concrete works [2400 h] | 1,533.61 | 2400,00 | UDF_G4 | XC201130 | 2400 | 60 |  | 934 | 14 | 200 | 200 | C | CiC |  | X | C | XC20 | 1420 | C | 14 | X | mis | LND | 1420 | MO11 |  |  |  |  |  |  |  |  |  |  |  |  |  | x | P |  |
|  | N | **Structural Steel** |  |  | 2011-05-23 | 2011-12-21 |  |  |  |  |  |  |  |  |  |  |  |  |  |  |  |  |  |  |  |  |  |  |  |  |  |  |  |  |  |  |  |  |  |  |  |  |  |  |  |  |  |  |  |  |  |  |  |  |
| XN701401 |  | CA14 FlareKoDrum SK1400/01/02 - KMD Assy Drawings | milestone | 0d | 2011-05-23 A | 2011-05-23 A |  | 100% |  |  | finish on 2011-05-23 | TB26 - V - Construct-Winter partly * |  |  | 22t |  | XN701401 | 0 | 0 |  | 934 | 14 | 200 | 200 | C | LND | KMD | X | N | XN05 | 1420 | N | 14 | X | SS | LND | 1420 |  |  |  |  |  |  | x |  |  |  |  |  |  |  |  |  | XNK |
| XN711401 |  | CA14 FlareKoDrum SK1400/01/02 - Steel Deliveries | milestone | 0d | 2011-09-01 | 2011-09-01 |  |  | 0d | 42d | finish on 2011-09-01 | TB26 - 3 - Construction Normal 7days * CA17 |  |  | 22t |  | XN711401 | 0 | 0 |  | 934 | 14 | 200 | 200 | C | LND | SD | X | N | XN06 | 1420 | N | 14 | X | SS | LND | 1420 |  |  |  |  |  |  |  |  |  |  |  |  |  |  |  |  | XNK |
| XN301130 |  | CA14 FlareKoDrum SK1400/01/02 - Install Primary Steel |  | 20d | 2011-10-24 | 2011-11-16 | XN205301, P3N02CN (other project), XN701401, XN711401 FS+10d, XC911130 |  | 34d | 0d |  |  | Piperacks, Main Structures [15 t]; Piperacks, Main structures [637.5 h] | 1,448.61 | 637,50 |  | XN301130 | 637,5 | 0 |  | 934 | 14 | 200 | 200 | C | LND |  | X | N | XN20 | 1420 | N | 14 | X | SS | LND | 1420 | SM |  | t |  |  |  | x |  |  |  |  |  |  |  |  |  | XNK |
| XN401130 |  | CA14 FlareKoDrum SK1400/01/02 - Install Railings,Ladders,etc. |  | 30d | 2011-11-17 | 2011-12-21 | XN301130 SS+20d |  | 34d | 0d |  |  | Ladders & platforms | 206.94 | 0,00 |  | XN401130 | 0 | 0 |  | 934 | 14 | 200 | 200 | C | LND |  | X | N | XN40 | 1420 | N | 14 | X | SS | LND | 1420 | SM |  |  |  |  |  | x |  |  |  |  |  |  |  |  |  | XNK |
| XN601130 |  | CA14 FlareKoDrum SK1400/01/02 - Install Gratings |  | 30d | 2011-11-17 | 2011-12-21 | XN401130 FF, PN691130 (other project) |  | 34d | 0d |  |  | Grating [50 sqm]; Grating [187.5 h] | 8,019.1 | 187,50 |  | XN601130 | 187,5 | 0 |  | 934 | 14 | 200 | 200 | C | LND |  | X | N | XN60 | 1420 | N | 14 | X | SS | LND | 1420 | SM |  |  |  |  |  |  |  |  |  |  |  |  |  |  |  | XNK |

Notes:
- XW501410: P3 Activity Log Info: Clarification Surface Protection during Prefab
- XN711401: Scope: 09.02.2011: weight: 15 ton - May 15 ton

| ID | WBS | Activity | Duration | Start | Finish | Predecessors | Complete | Total float | Free float | Constraint | Calendar | Resources | Cost | Actual cost | TB26 Ressource Budget | UDF_Weight (ton) | WEIGHT | UDF_LEVEL | UDF_TAG No | UDF_Object No | UDF_DELIVERY DATE PO | UDF_DELIVERY DATE DISPATCH PLANNED | UDF_DELIVERY DATE TO SITE PLANNED | UDF_DELIVERY DATE SITE NEED DATE | UDF_PACKAGE | UDF_SAVE ACT ID | UDF_BUDGETED LABOR UNIT | UDF_ACTUAL LABOR UNIT | Constr. Area | Zeigen/n. Zeigen | WBS Phase | WBS Discipline | WBS Objects | UDF_PO No | UDF_SUPPLIER | UDF_CONTRACT START DATE | UDF_CONTRACT FINISH DATE | UDF_CONTRACT ITEM | Department | Type of Work | PMT-Area | PMT-Schedule Org | PMT-Phase | PMT-Respons. | WBS Type of Work | Russia WBS Discipline (Russia) | Russia Construction Area | Russia WBS Phase | IMS | UPT | Russia WBS Objects | UDF_PLANNED START | UDF_PLANNED FINISH | UDF_CONTRACT INDICATOR | Subcontractor | TB26 Semantics | TB26 Material Res Values | UDF_ELECTRICAL START | UDF_ELECTRICAL FINISH | UDF_CHECK BASELINE | Filter | UDF_CONTRACT FINISH DATE REV1 | UDF_CONTRACT START DATE REV1 | UDF_Vendor Representatives | UDF_PENALIZED FINISH |
| --- | --- | --- | --- | --- | --- | --- | --- | --- | --- | --- | --- | --- | --- | --- | --- | --- | --- | --- | --- | --- | --- | --- | --- | --- | --- | --- | --- | --- | --- | --- | --- | --- | --- | --- | --- | --- | --- | --- | --- | --- | --- | --- | --- | --- | --- | --- | --- | --- | --- | --- | --- | --- | --- | --- | --- | --- | --- | --- | --- | --- | --- | --- | --- | --- | --- |
|  | H | **HVAC** |  |  |  |  |  |  |  |  |  |  |  |  |  |  |  |  |  |  |  |  |  |  |  |  |  |  |  |  |  |  |  |  |  |  |  |  |  |  |  |  |  |  |  |  |  |  |  |  |  |  |  |  |  |  |  |  |  |  |  |  |  |  |  |
|  | U | **Package Units** |  |  |  |  |  |  |  |  |  |  |  |  |  |  |  |  |  |  |  |  |  |  |  |  |  |  |  |  |  |  |  |  |  |  |  |  |  |  |  |  |  |  |  |  |  |  |  |  |  |  |  |  |  |  |  |  |  |  |  |  |  |  |  |
|  | B | **Mechanical - Stationary Equipment** |  | 2011-11-17 | 2011-11-28 |  |  |  |  |  |  |  |  |  |  |  |  |  |  |  |  |  |  |  |  |  |  |  |  |  |  |  |  |  |  |  |  |  |  |  |  |  |  |  |  |  |  |  |  |  |  |  |  |  |  |  |  |  |  |  |  |  |  |  |  |
| V-21701 |  | PRESSURE EQUIPMENT | 10d | 2011-11-17 | 2011-11-28 | XB101130 SS |  | 104d | 0d |  |  | Static Equipment > 10 tons [31 t]; Static equipment >10t [2325 h] | 93,000 |  | 2325,00 | 31 | 31000 | concrete +0.00 | V-21701 | SK1420 | 2010-12-31 | 2011-01-15 | 2011-01-30 | 2011-02-18 | A02A LARGE DRUMS (V-21701/24101/21901 | V-21701 | 2325 | 0 | 14 | EQ | X | B | 1420 |  |  |  |  |  |  |  |  |  |  |  |  |  |  |  |  |  |  |  |  |  |  |  |  |  |  |  |  |  |  |  |  |
| V-21702 |  | PRESSURE EQUIPMENT | 10d | 2011-11-17 | 2011-11-28 | XB101130 SS |  | 104d | 0d |  |  | Static Equipment < 10 tons [2.6 t]; Static equipment < 10t [260 h] | 10,400 |  | 260,00 |  | 31000 | concrete +0.00 | V-21702 | SK1420 | 2010-12-31 | 2011-01-15 | 2011-01-30 | 2011-02-18 | A01 PRESSURE EQUIPMENT | V-21702 | 260 | 0 | 14 | EQ | X | B | 1420 | 2 DC 9450 | Tambovskij Zavod |  |  |  |  |  |  |  |  |  |  |  |  |  |  |  |  |  |  |  |  |  |  |  |  |  |  |  |  |  |  |
| XB101130 |  | CA14 FlareKoDrum - Install Static Eqpt | 10d | 2011-11-17 | 2011-11-28 | P3A02AS1 (other project), XC201130, ER291400 (other project) FS+40d, XN301130 |  | 104d | 0d |  |  |  |  |  | 31 |  |  |  |  |  |  |  |  |  |  | XB101130 | 0 | 0 | 14 |  | X | B | 1420 |  |  | 2011-04-10 | 2011-07-30 | E-08-01-11 | 934 | XBB | 200 | 200 | C | LND | XB10 | B | 14 | X | EQ | LND | 1420 |  |  |  |  |  |  |  |  |  |  |  |  |  |  |
|  | M | **Mechanical - Rotating Equipment** |  |  |  |  |  |  |  |  |  |  |  |  |  |  |  |  |  |  |  |  |  |  |  |  |  |  |  |  |  |  |  |  |  |  |  |  |  |  |  |  |  |  |  |  |  |  |  |  |  |  |  |  |  |  |  |  |  |  |  |  |  |  |  |
|  | R | **Piping** |  | 2011-11-29 | 2012-04-24 |  |  |  |  |  |  |  |  |  |  |  |  |  |  |  |  |  |  |  |  |  |  |  |  |  |  |  |  |  |  |  |  |  |  |  |  |  |  |  |  |  |  |  |  |  |  |  |  |  |  |  |  |  |  |  |  |  |  |  |  |
| XR201130 |  | CA14 FlareKoDrum - Piping Prefabrication | 20d | 2011-11-29 | 2011-12-21 | ER491130 (other project), XR500C00 FS+15d |  | 34d | 0d | as late as possible |  | A/G piping prefabrication [430 Fpi]; A/G Piping (Prefab) [1612.5 h] | 3,344.37 |  | 1612,50 |  |  |  |  |  |  |  |  |  |  | XR201130 | 1612,5 | 0 | 14 |  | X | R | 1420 |  |  |  |  |  | 934 |  | 200 | 200 | C | LND | XR20 | R | 14 | X | PRP | LND | 1420 |  |  |  |  |  |  |  |  |  |  |  |  |  |  |
| XR401130 |  | CA14 FlareKoDrum - Piping Installation | 40d | 2011-12-22 | 2012-02-13 | P3J02AS (other project), XN601130, XR201130, P3J04IS (other project), P3J04CS1 (other project) |  | 34d | 0d |  |  | A/G piping field installation [525 Fpi]; Control & Shut-off valves [8 pcs]; Install Control & Shut-off Valves [42 h]; A/G Piping (Field) [3281.25 h] | 13,564.54 |  | 3323,25 |  |  |  |  |  |  |  |  |  |  | XR401130 | 3323,25 | 0 | 14 |  | X | R | 1420 |  |  | 2011-06-30 | 2011-09-30 | E-06-03-05 | 934 |  | 200 | 200 | C | LND | XR40 | R | 14 | X | PI | LND | 1420 | 2011-09-10 |  |  |  |  |  |  |  |  |  |  |  |  |  |
| XR601130 |  | CA14 FlareKoDrum - Piping Pressure Tests | 20d | 2012-03-19 | 2012-04-12 | XR401130 FF+20d, XR605201 SS |  | 5d | 0d |  | TB26 - V - Construct-Winter partly * |  |  |  | 112 |  |  |  |  |  |  |  |  |  |  | XR601130 | 0 | 0 | 14 |  | X | R | 1420 |  |  | 2011-06-30 | 2011-09-30 | E-06-03-05 | 934 |  | 200 | 200 | C | LND | XR60 | R | 14 | X | HY | LND | 1420 |  |  |  |  |  |  |  |  |  |  |  |  |  |  |
| XR801130 |  | CA14 FlareKoDrum - Piping Reinstatement | 20d | 2012-04-02 | 2012-04-24 | XR601130 FF+10d, IMS-C-000360 FF |  | 5d | 0d |  | TB26 - V - Construct-Winter partly * |  |  |  | 56 |  |  |  |  |  |  |  |  |  |  | XR801130 | 0 | 0 | 14 |  | X | R | 1420 |  |  | 2011-06-30 | 2011-09-30 | E-06-03-05 | 934 |  | 200 | 200 | C | LND | XR80 | R | 14 | X | PI | LND | 1420 |  | 2011-12-12 |  |  |  |  |  |  |  |  |  |  |  |  |
|  | E | **Electrical** |  | 2011-07-13 | 2012-08-03 |  |  |  |  |  |  |  |  |  |  |  |  |  |  |  |  |  |  |  |  |  |  |  |  |  |  |  |  |  |  |  |  |  |  |  |  |  |  |  |  |  |  |  |  |  |  |  |  |  |  |  |  |  |  |  |  |  |  |  |  |
| XC911130 |  | CA14 FlareKoDrum - Install Earthing System_CIVIL | 5d | 2011-07-13 A | 2011-07-18 A | XC201130 FF, IMS-C-000230 FF, EE901130 (other project) | 100% |  |  |  |  | Grounding & Lightning [100 pcs]; Grounding & Lightning [1125 h] | 45,000 | 45,000 | 1125,00 |  |  |  |  |  |  |  |  |  |  | XC911130 | 1125 | 0 | 14 |  | X | C | 1420 |  |  |  |  |  | 934 |  | 200 | 200 | C | LND | XE91 | C | 14 | X | EA | LND | 1420 |  |  | UDF_G4 | MO11 |  |  |  |  |  |  |  |  |  |  |
| XE911131 |  | CA14 FlareKoDrum - Install Earthing System_E/I | 5d | 2011-11-29 | 2011-12-03 | XN301130, V-21701, V-21702 |  | 169d | 236.5d |  |  |  |  |  | 115 |  |  |  |  |  |  |  |  |  |  | XE911131 | 0 | 0 | 14 |  | X | E | 1420 |  |  |  |  |  | 934 |  | 200 | 200 | C | LND | XE91 | E | 14 | X | EA | LND | 1420 |  |  | UDF_G3 | URMA |  |  |  |  |  |  |  |  |  |  |
| XE401130 |  | CA14 FlareKoDrum - Install Cable Trays | 10d | 2012-01-21 | 2012-02-01 | XN205301, XN301130, XR401130 SS+20d |  | 74d | 0d |  |  | Cable trays/conduits [100 m]; Cable trays [300 h] | 12,000 |  | 300,00 |  |  |  |  |  |  |  |  |  |  | XE401130 | 300 | 0 | 14 |  | X | E | 1420 |  |  |  |  |  | 934 |  | 200 | 200 | C | LND | XE40 | E | 14 | X | EL | LND | 1420 |  |  | UDF_G3 | URMA | m | 300 | 2011-11-03 | 2011-12-20 | x |  |  |  |  |  |
| XE341130 |  | CA14 FlareKoDrum - Install Local Operation Panels | 10d | 2012-02-02 | 2012-02-13 | XE401130, XR401130 SS+20d, V-21702, V-21701 |  | 106d | 134.5d |  |  | Field Panels [2 pcs]; Field panels [40 h] | 1,600 |  | 40,00 |  |  |  |  |  |  |  |  |  |  | XE341130 | 40 | 0 | 14 |  | X | E | 1420 |  |  |  |  |  | 934 |  | 200 | 200 | C | LND | XE34 | E | 14 | X | EL | LND | 1420 |  |  | UDF_G3 | URMA |  |  |  |  |  |  |  |  |  |  |
| XE701130 |  | CA14 FlareKoDrum - Install Lighting &Small Power | 20d | 2012-03-05 | 2012-04-02 | XR401130, XE401130, EE761130 (other project), XJ421130, P3E09S (other project), XP341610 FS+50d |  | 74d | 0d |  | TB26 - V - Construct-Winter partly * | Cable Pulling [600 m]; Lighting illuminates [60 pcs]; Lighting (iluminates) [600 h]; Cable pulling [300 h] | 36,000 |  | 900,00 |  |  |  |  |  |  |  |  |  |  | XE701130 | 900 | 0 | 14 |  | X | E | 1420 |  |  | 2011-05-10 | 2012-01-31 | E-16-03-01 | 934 |  | 200 | 200 | C | LND | XE70 | E | 14 | X | EL | LND | 1420 |  |  |  | URMA |  |  |  |  |  | x | 2012-05-10 | 2011-08-15 |  |  |
| XE921130 |  | CA14 FlareKoDrum - Install Fire Detection System | 15d | 2012-04-03 | 2012-04-19 | XE701130, XE701130 SS+10d |  | 291.5d | 0d |  | TB26 - V - Construct-Winter partly * | Fire Detection System; Fire detection system |  |  | 0,00 |  |  |  |  |  |  |  |  |  |  | XE921130 | 0 | 0 | 14 |  | X | E | 1420 |  |  |  |  |  | 934 |  | 200 | 200 | C | UIO | XE92 | E | 14 | X | FGDS | LND | 1420 |  |  |  |  |  |  |  |  | x | x |  |  |  |  |
| XE961130 |  | CA14 FlareKoDrum - Install Communication System | 15d | 2012-04-03 | 2012-04-19 | XE701130, XE921130 SS, XJ421130 |  | 291.5d |  |  | TB26 - V - Construct-Winter partly * | Communication System |  |  | 0,00 |  |  |  |  |  |  |  |  |  |  | XE961130 | 0 | 0 | 14 |  | X | E | 1420 |  |  |  |  |  | 934 |  | 200 | 200 | C | LND | XE96 | E | 15 | X | CS | LND | 1510 |  |  |  |  |  |  |  |  | x | x |  |  |  |  |
| XE801130 |  | CA14 FlareKoDrum - Install Heat Tracing | 40d | 2012-05-09 | 2012-06-25 | XE800C00 SS, P3E19S (other project), XW501130 FF+20d, E3E1950 (other project), V-21701, XR401130, XR601130 FF+1d |  | 5d | 0d |  | TB26 - V - Construct-Winter partly * | Electrical Heat Tracing [1000 m]; Electrical heat tracing [500 h] | 20,000 |  | 500,00 |  |  |  |  |  |  |  |  |  |  | XE801130 | 500 | 0 | 14 |  | X | E | 1420 |  |  | 2011-06-20 | 2012-03-20 | E-16-04-01 | 934 |  | 200 | 200 | C | LND | XE80 | E | 14 | X | HT | LND | 1420 |  |  | UDF_G3 | URMA |  |  |  |  |  |  | 2012-06-30 | 2011-09-15 | 005 |  |
| XE501130 |  | CA14 FlareKoDrum - Cable Pulling Electric | 30d | 2012-06-18 | 2012-07-23 | P3E15AS (other project), P3E15BS (other project), P3E15CS (other project), XE401130, XE500C01, XE505401 SS+15d, XE505102 SS+10d, XE505103 SS+10d, XE505104 SS+10d, XE505601 SS+8d |  | -28.5d | 0d |  | TB26 - V - Construct-Winter partly * | Cable Pulling [2400 m]; Cable pulling [1200 h] | 48,000 |  | 1200,00 |  |  |  |  |  |  |  |  |  |  | XE501130 | 1200 | 0 | 14 |  | X | E | 1420 |  |  | 2011-05-20 | 2012-02-10 | E-16-01-01 | 934 |  | 200 | 200 | C | LND | XE50 | E | 14 | X | EL | LND | 1420 |  |  | UDF_G3 | URMA | m | 2500 | 2011-12-21 | 2012-04-02 |  |  | 2012-07-01 | 2011-10-01 |  |  |
| XE601130 |  | CA14 FlareKoDrum - Cable Termination & Testing | 30d | 2012-06-29 | 2012-08-03 | IMS-C-000390 FF, IMS-C-000380 FF, XE501130 FF+10d, XE341130 FF+8d, V-21702, V-21701 |  | -28.5d | 19d |  |  | Cable connecting [30 pcs]; Cable connecting [75 h] | 3,000 |  | 75,00 |  |  |  |  |  |  |  |  |  |  | XE601130 | 75 | 0 | 14 |  | X | E | 1420 |  |  | 2011-04-20 | 2011-11-30 | E-16-02-01 | 934 |  | 200 | 200 | C | LND | XE60 | E | 14 | X | ET | LND | 1420 |  |  | UDF_G3 | URMA |  |  |  |  |  |  | 2012-08-14 | 2011-12-10 |  |  |
|  | J | **Instrumentation** |  | 2012-01-23 | 2012-09-29 |  |  |  |  |  |  |  |  |  |  |  |  |  |  |  |  |  |  |  |  |  |  |  |  |  |  |  |  |  |  |  |  |  |  |  |  |  |  |  |  |  |  |  |  |  |  |  |  |  |  |  |  |  |  |  |  |  |  |  |  |
| XJ321130 |  | CA14 FlareKoDrum - Install Junction Boxes | 10d | 2012-01-23 | 2012-02-13 | XN601130, P3J06ES (other project) FS+14d, EJ321130 (other project), XR401130 SS+20d, P3J06FS (other project), V-21701, V-21702 |  | 44d | 0d |  | TB26 - V - Construct-Winter partly * | Junction Boxes/Cabinets/Panels [18 pcs]; Install Junction Boxes/ Cabinets/ Panels [450 h] | 18,000 |  | 450,00 |  |  |  |  |  |  |  |  |  |  | XJ321130 | 450 | 0 | 14 |  | X | J | 1420 |  |  |  |  |  | 934 |  | 200 | 200 | C | LND | XJ32 | J | 14 | X | IN | LND | 1420 |  |  | UDF_G3 | URMA |  |  |  |  |  |  |  |  |  |  |
| XJ421130 |  | CA14 FlareKoDrum - Install Secondary Cable Trays | 20d | 2012-02-08 | 2012-03-02 | XE401130 FF, XJ321130 FF+10d, XR401130 SS+20d, V-21701, V-21702 |  | 49d | 1d |  |  | Secondary cable trays [250 m]; Install secondary cable trays [937.5 h] | 37,500 |  | 937,50 |  |  |  |  |  |  |  |  |  |  | XJ421130 | 937,5 | 0 | 14 |  | X | J | 1420 |  |  |  |  |  | 934 |  | 200 | 200 | C | LND | XJ42 | J | 14 | X | IN | LND | 1420 |  |  |  | URMA | m | 220 | 2011-11-28 | 2011-12-31 | x | x |  |  |  |  |
| XJ441130 |  | CA14 FlareKoDrum - Install Conduits to Instrm | 20d | 2012-03-05 | 2012-04-02 | XJ321130, XR401130 SS+20d, XE401130, XJ421130, V-21701, V-21702 |  | 44d | 19d |  | TB26 - V - Construct-Winter partly * |  |  |  |  |  |  |  |  |  |  |  |  |  |  | XJ441130 | 0 | 0 | 14 |  | X | J | 1420 |  |  |  |  |  | 934 |  | 200 | 200 | C | LND | XJ44 | J | 14 | X | IN | LND | 1420 |  |  |  | URMA |  |  |  |  |  |  |  |  |  |  |
| XJ301130 |  | CA14 FlareKoDrum - Install Field Instruments | 20d | 2012-04-02 | 2012-04-24 | XR801130 FF, P3J05S (other project), EJ361130 (other project), P3J12BS (other project), P3J13BS (other project), P3J07AS (other project), P3J12DS (other project), P3J13S (other project), P3J13CS (other project), P3J14S (other project), P3J12AS (other project), P3J04ES (other project), P3J14BS (other project), P3J13AS (other project), P3J14AS (other project), XR401130 SS+40d, V-21701, V-21702 |  | 15d | 0d |  |  | Field Instruments [43 pcs]; Install field instruments [237 h] | 9,460 |  | 237,00 |  |  |  |  |  |  |  |  |  |  | XJ301130 | 237 | 0 | 14 |  | X | J | 1420 |  |  |  |  |  | 934 |  | 200 | 200 | C | LND | XJ30 | J | 14 | X | IN | LND | 1420 |  |  | UDF_G3 | URMA |  |  |  |  |  |  |  |  |  |  |
| XJ541130 |  | CA14 FlareKoDrum - Pulling Singlecore Cables | 20d | 2012-04-13 | 2012-05-07 | XE500C01, EJ801130 (other project), XJ441130 SS+10d, XJ301130 FF+10d, XJ421130 |  | 30d | 15d |  | TB26 - V - Construct-Winter partly * | Singlecore cables [3700 m]; Pull singlecore cables [2775 h] | 111,000 |  | 2775,00 |  |  |  |  |  |  |  |  |  |  | XJ541130 | 2775 | 0 | 14 |  | X | J | 1420 |  |  |  |  |  | 934 |  | 200 | 200 | C | LND | XJ54 | J | 14 | X | IN | LND | 1420 |  |  |  | URMA | m | 3570 | 2012-03-30 | 2012-04-21 |  |  |  |  |  |  |
| XJ701130 |  | CA14 FlareKoDrum - Instrument Tubing | 20d | 2012-04-13 | 2012-05-07 | XJ301130 FF+10d, XR401130 |  | 25d | 10d |  | TB26 - V - Construct-Winter partly * |  |  |  |  |  |  |  |  |  |  |  |  |  |  | XJ701130 | 0 | 0 | 14 |  | X | J | 1420 |  |  |  |  |  | 934 |  | 200 | 200 | C | LND | XJ70 | J | 14 | X | IN | LND | 1420 |  |  |  | URMA |  |  |  |  |  |  |  |  |  |  |
| XJ391130 |  | CA14 FlareKoDrum - Install Earthing Field Eqpt | 10d | 2012-05-09 | 2012-05-19 | XJ301130 FF+20d, XJ441130, XJ421130 |  | 15d | 0d |  | TB26 - V - Construct-Winter partly * |  |  |  |  |  |  |  |  |  |  |  |  |  |  | XJ391130 | 0 | 0 | 14 |  | X | J | 1420 |  |  |  |  |  | 934 |  | 200 | 200 | C | LND | XJ39 | J | 14 | X | IN | LND | 1420 |  |  |  | URMA |  |  |  |  |  |  |  |  |  |  |
| XJ641130 |  | CA14 FlareKoDrum - Termin Singlecore Cables | 20d | 2012-05-21 | 2012-06-13 | XJ301130, XJ541130 FF+15d, XJ701130, XJ321130, XJ391130 |  | 15d | 62.5d |  |  | Termination Field [705 mhr]; Termination field [705 h] | 70,500 |  | 705,00 |  |  |  |  |  |  |  |  |  |  | XJ641130 | 705 | 0 | 14 |  | X | J | 1420 |  |  |  |  |  | 934 |  | 200 | 200 | C | LND | XJ64 | J | 14 | X | IN | LND | 1420 |  |  |  | URMA |  |  |  |  |  |  |  |  |  |  |
| XJ521130 |  | CA14 FlareKoDrum - Pulling Multicore Cables | 20d | 2012-06-07 | 2012-07-02 | XJ525301 SS+8d, XE500C01, XJ321130 SS+15d, XE401130, XJ525401 SS+18d, XJ525102 SS+15d, XJ525103 SS+12d, XJ525104 SS+10d |  | -10.5d | 0d |  | TB26 - V - Construct-Winter partly * | Multicore cables [2000 m]; Pull multicore cables [1000 h] | 40,000 |  | 1000,00 |  |  |  |  |  |  |  |  |  |  | XJ521130 | 1000 | 0 | 14 |  | X | J | 1420 |  |  | 2011-05-20 | 2012-03-10 | E-17-01-01 | 934 |  | 200 | 200 | C | LND | XJ52 | J | 14 | X | IN | LND | 1420 |  |  |  | URMA | m | 1450 | 2012-03-03 | 2012-03-27 |  |  | 2012-06-16 | 2011-11-01 |  |  |
| XJ621130 |  | CA14 FlareKoDrum - Termin Multicore Cables | 20d | 2012-06-20 | 2012-07-13 | XJ321130, XJ521130 FF+10d |  | -10.5d | 37d |  |  | Termination Field [705 mhr]; Termination field [705 h] | 70,500 |  | 705,00 |  |  |  |  |  |  |  |  |  |  | XJ621130 | 705 | 0 | 14 |  | X | J | 1420 |  |  | 2011-05-20 | 2012-03-10 | E-17-01-01 | 934 |  | 200 | 200 | C | LND | XJ62 | J | 14 | X | IN | LND | 1420 |  |  |  | URMA |  |  |  |  |  |  | 2012-06-16 | 2011-11-01 |  |  |
| XJ801130 |  | CA14 FlareKoDrum - Inspections/ Mech. Acceptance/ Loop Checks | 30d | 2012-08-25 | 2012-09-29 | XJ701130, XE601130, X3J120, XJ391130 SS+10d, XJ641130, X030410030, XJ621130 |  | -30.5d | 20d |  |  | Loop Checks [160 pcs]; Loop checks [800 h] | 32,000 |  | 800,00 |  |  |  |  |  |  |  |  |  |  | XJ801130 | 800 | 0 | 14 |  | X | J | 1420 |  |  | 2011-06-10 | 2012-04-30 | E-17-02-01 | 934 |  | 200 | 200 | C | LND | XJ80 | J | 14 | X | LT | LND | 1420 |  |  |  | URMA |  |  |  |  |  |  | 2012-08-18 | 2012-03-01 |  | 2012-08-18 |

| ID | WBS | Activity | Type | Duration | Start | Finish | Predecessors | Complete | Total float | Free float | Constraint | Calendar | Resources | Cost | Actual cost | TB26 Ressource Budget | UDF_SAVE ACT ID | UDF_BUDGETED LABOR UNIT | UDF_ACTUAL LABOR UNIT | Department | Constr. Area | PMT-Area | PMT-Schedule Org | PMT-Phase | PMT-Respons. | WBS Phase | WBS Discipline | WBS Type of Work | WBS Objects | Russia WBS Discipline (Russia) | Russia Construction Area | Russia WBS Phase | IMS | UPT | Russia WBS Objects | UDF_CONTRACT FINISH DATE | UDF_CONTRACT ITEM | Type of Work | Subcontractor | Inquiry/Order No | UDF_Concrete | UDF_SELECT UPDATE PROGRESS | Comments | UDF_Text4 | UDF_CONTRACT START DATE | TB26 Semantics | Zeigen/n. Zeigen | 4 week lookahead |
| --- | --- | --- | --- | --- | --- | --- | --- | --- | --- | --- | --- | --- | --- | --- | --- | --- | --- | --- | --- | --- | --- | --- | --- | --- | --- | --- | --- | --- | --- | --- | --- | --- | --- | --- | --- | --- | --- | --- | --- | --- | --- | --- | --- | --- | --- | --- | --- | --- |
|  | S | **Safety & Environment** |  |  |  |  |  |  |  |  |  |  |  |  |  |  |  |  |  |  |  |  |  |  |  |  |  |  |  |  |  |  |  |  |  |  |  |  |  |  |  |  |  |  |  |  |  |  |
|  | W | **Painting** |  |  | 2012-04-07 | 2012-05-31 |  |  |  |  |  |  |  |  |  |  |  |  |  |  |  |  |  |  |  |  |  |  |  |  |  |  |  |  |  |  |  |  |  |  |  |  |  |  |  |  |  |  |
| XW501130 |  | CA14 FlareKoDrum - Surf.Protection Piping |  | 45d | 2012-04-07 | 2012-05-31 | XR801130 FF+30d, XR201130 SS |  | 5d | 0d |  |  | Piping painting [141 sqm]; Piping painting [353 h] | 564.66 |  | 353,00 | XW501130 | 353 | 0 | 934 | 14 | 200 | 200 | C | LND | X | W | XW50 | 1420 | W | 14 | X | PA | LND | 1420 |  |  |  |  |  |  |  |  |  |  |  |  |  |
|  | V | **Insulation** |  |  | 2012-06-01 | 2012-07-25 |  |  |  |  |  |  |  |  |  |  |  |  |  |  |  |  |  |  |  |  |  |  |  |  |  |  |  |  |  |  |  |  |  |  |  |  |  |  |  |  |  |  |
| XV301130 |  | CA14 FlareKoDrum - Insulation Equipment |  | 40d | 2012-06-01 | 2012-07-18 | XR401130, XE801130 FF+20d, XE801130 SS+20d |  | 26d | 0d |  | TB26 - V - Construct-Winter partly * | Equipment insulation [100 sqm]; Equipment insulation [1250 h] | 403.54 |  | 1250,00 | XV301130 | 1250 | 0 | 934 | 14 | 200 | 200 | C | LND | X | V | XV30 | 1420 | V | 14 | X | INS | LND | 1420 | 2012-03-30 | E-13-03 |  |  |  |  |  |  |  |  |  |  |  |
| XV501130 |  | CA14 FlareKoDrum - Insulation Piping |  | 40d | 2012-06-08 | 2012-07-25 | XR601130, XE801130 FF+20d, XW501130 FF+20d, XV301130 FF+6d |  | 26d | 76.5d |  | TB26 - V - Construct-Winter partly * | Piping insulation [120 sqm]; Piping insulation [900 h] | 1,608.26 |  | 900,00 | XV501130 | 900 | 0 | 934 | 14 | 200 | 200 | C | LND | X | V | XV50 | 1420 | V | 14 | X | INS | LND | 1420 | 2012-04-30 | E-13-01 |  |  |  |  |  |  |  |  |  |  |  |
|  | 15 | **CA15 - Instrument Air / Lifting Stations** |  |  | 2008-09-24 | 2012-09-18 |  |  |  |  |  |  |  |  |  |  |  |  |  |  |  |  |  |  |  |  |  |  |  |  |  |  |  |  |  |  |  |  |  |  |  |  |  |  |  |  |  |  |
|  | 00 | **CA15 - General** |  |  | 2008-09-24 | 2012-09-18 |  |  |  |  |  |  |  |  |  |  |  |  |  |  |  |  |  |  |  |  |  |  |  |  |  |  |  |  |  |  |  |  |  |  |  |  |  |  |  |  |  |  |
|  | 0B | **General Activities** |  |  | 2012-07-30 | 2012-09-18 |  |  |  |  |  |  |  |  |  |  |  |  |  |  |  |  |  |  |  |  |  |  |  |  |  |  |  |  |  |  |  |  |  |  |  |  |  |  |  |  |  |  |
| X0101510 |  | CA15 General - Construction Completion | milestone | 0d | 2012-07-30 | 2012-07-30 | XJ641510, XJ621510, XE501510, XR401510, XE601510, XE701500, XB001510, XJ541510, XM101510, XE911511 |  | -30d | 49.5d |  | TB26 - 2 - Manuf and Delivy |  |  |  |  | X0101510 | 0 | 0 | 934 | 15 | 200 | 200 | C | LND | X | 0B | X010 | 1500 | 0 | 15 | X | MC | LND | 1500 |  |  | XNK |  |  |  |  |  |  |  |  |  |  |
| X0101500 |  | CA15 General - Mechanical Completion | milestone | 0d | 2012-09-18 | 2012-09-18 | XV301510 FF, XE701500, P3M17S (other project), XC601500 FF, XE601510, XE911511, XJ801510 FF, X0101510, XV501510 FF |  | -24.5d | 102d |  | TB26 - 2 - Manuf and Delivy |  |  |  |  | X0101500 | 0 | 0 | 934 | 15 | 200 | 200 | C | LND | X | 0B | X010 | 1500 | 0 | 15 | X | MC | LND | 1500 |  |  | XNK |  |  |  |  |  |  |  |  |  |  |
|  | C | **Civil Work** |  |  | 2008-09-24 | 2012-03-14 |  |  |  |  |  |  |  |  |  |  |  |  |  |  |  |  |  |  |  |  |  |  |  |  |  |  |  |  |  |  |  |  |  |  |  |  |  |  |  |  |  |  |
| XC111510 |  | CA15 General - Excavation&Surface Prep by U/I/O |  | 294d | 2008-09-24 A | 2009-09-30 A | XC111600 SS | 100% |  |  |  |  |  |  |  |  | XC111510 | 0 | 0 | 934 | 15 | 200 | 200 | C | UIO | X | C | XC11 | 1500 | C | 15 | X | CW | LND | 1500 |  |  |  | MO11 |  |  |  |  |  |  |  |  |  |
| XC11151005 |  | CA15 General - Excavation |  | 8d | 2010-05-03 A | 2010-05-11 A | XC111510 | 100% |  |  |  |  | Excavation [4000 cbm]; Excavation [2000 h]; Sub Base for Concrete/Paving&Roads (Gravel) [4000 cbm]; Subbase for Concrete [4000 h] | 560,000 | 560,000 | 6000,00 | XC11151005 | 6000 | 6000 | 934 | 15 | 200 | 200 | C | MO02 | X | C | XC11 | 1500 | C | 10 | X | P | LND | 1010 |  |  |  | MO11 | 999 |  |  |  |  |  |  |  |  |
| XC151510 |  | CA15 General - Piling |  | 5d | 2010-11-18 A | 2010-11-23 A | XC111510, XC155201 FS+15d, XC11151005 FS+40d, F2910, EC151510 (other project) FS+5d | 100% |  |  |  |  | Piles driven [20 pcs]; Piles driven [150 h] | 36.95 |  | 150,00 | XC151510 | 150 | 150 | 934 | 15 | 200 | 200 | C | MO02 | X | C | XC15 | 1500 | C | 15 | X | P | LND | 1500 |  |  |  | MO11 |  |  |  |  |  |  |  |  |  |
| XC301510 |  | CA15 General - UG Installation (incl. Precast Manholes) |  | 30d | 2011-10-03 | 2011-11-07 | P3R02BS (other project), P3R02AS1 (other project), EC301510 (other project) FS+20d, XC300C00, P3R02S1 (other project), ER441510 (other project), XC201510 FF+30d, XC310C00 |  | -1d | 0d | start on or after 2011-10-03 |  |  |  |  |  | XC301510 | 0 | 0 | 934 | 15 | 200 | 200 | C | CiC | X | C | XC30 | 1500 | C | 15 | X | UG | LND | 1500 |  |  |  |  |  | 1 | 27.8. |  |  |  |  |  |  |
| XC191510 |  | CA15 General - Backfill |  | 15d | 2011-10-22 | 2011-11-14 | XC911510 FF+10d, XC301510 FF+5d |  | 119d | 0d |  | TB26 - T - Construct-Winter-3 (Dec/Jan/Feb free) * | Backfill & Compaction [3000 cbm]; Backfill & Compaction [4500 h] | 270,000 |  | 4500,00 | XC191510 | 4500 | 0 | 934 | 15 | 200 | 200 | C | CiC | X | C | XC19 | 1500 | C | 15 | X | UG | LND | 1500 |  |  |  | MO11 |  |  |  |  |  |  |  |  |  |
| XC601500 |  | CA15 General - Paving |  | 30d | 2012-02-07 | 2012-03-14 | XC191510 SS+20d, XC191510 FF+20d, EC601500 (other project) FS+20d, EC601400 (other project) FS+20d |  | 137d | 157.5d |  |  | Concrete paved areas & concrete Roads [2000 sqm]; Open ditches; Gravel [3300 sqm]; Concrete paved areas & concrete roads [7500 h]; open ditches; Gravel [165 h] | 6,600 |  | 7665,00 | XC601500 | 7665 | 0 | 934 | 15 | 200 | 200 | C | CiC | X | C | XC60 | 1500 | C | 15 | X | PV | LND | 1500 |  |  |  | MO11 |  | 1 |  |  |  |  |  |  |  |
|  | 01 | **CA15 - Air Buffer Vessel Platform** |  |  |  |  |  |  |  |  |  |  |  |  |  |  |  |  |  |  |  |  |  |  |  |  |  |  |  |  |  |  |  |  |  |  |  |  |  |  |  |  |  |  |  |  |  |  |
|  | 04 | **CA15 - Auxiliary Structures** |  |  |  |  |  |  |  |  |  |  |  |  |  |  |  |  |  |  |  |  |  |  |  |  |  |  |  |  |  |  |  |  |  |  |  |  |  |  |  |  |  |  |  |  |  |  |
|  | 10 | **CA15 - Air Buffer Vessel Section** |  |  | 2011-05-14 | 2012-09-18 |  |  |  |  |  |  |  |  |  |  |  |  |  |  |  |  |  |  |  |  |  |  |  |  |  |  |  |  |  |  |  |  |  |  |  |  |  |  |  |  |  |  |
| XN701500 |  | SK1602 EDB - Install Primary Steel |  | 5d | 2012-05-02 | 2012-05-07 | XC201602 |  | 277.5d |  |  | TB26 - V - Construct-Winter partly * | Piperacks, Main Structures [5 t]; Piperacks, Main structures [212.5 h] | 8,500 |  | 212,50 | XN701500 | 212,5 | 0 | 934 | 16 | 200 | 200 | C | LND | X | C | XN20 | 1610 | N | 15 | X | SS | LND | 1510 | 2011-02-28 | E-04-09 | XNK | ChSK |  |  |  | 79>90 modified | CA16 - critical - CW05 | 2011-01-10 | t | D | x |
|  | C | **Civil Work** |  |  | 2011-05-28 | 2011-05-30 |  |  |  |  |  |  |  |  |  |  |  |  |  |  |  |  |  |  |  |  |  |  |  |  |  |  |  |  |  |  |  |  |  |  |  |  |  |  |  |  |  |  |
| XC201510 |  | CA15 Air Buffer - Concrete Works Foundations/Basins |  | 2d | 2011-05-28 A | 2011-05-30 A | EC45151115 (other project), EC441500 (other project), EC45151105 (other project) FS+64d, EC281510 (other project), XC151510 | 100% |  |  |  | TB26 - V - Construct-Winter partly * | Concrete works [20 cbm]; Concrete works [600 h] | 1,385.79 |  | 600,00 | XC201510 | 600 | 600 | 934 | 15 | 200 | 200 | C | CiC | X | C | XC20 | 1510 | C | 15 | X | mis | LND | 1510 |  |  |  | MO11 |  |  |  |  |  |  |  |  |  |

Notes:
- XW501130: P3 Activity Log Info: Clarification Surface Protection during Prefab
- XC111510: P3 Activity Log Info: incl. Dewatering/Drainage
- XC151510: P3 Activity Log Info: 25 dp expected
- XC301510: P3 Activity Log Info: Clarification Prefab Catch Basins/pulling pits
- XC201510: Current Status: 12.01.2011 (Oxana): diese Flдche dient bis auf weiteres / als Zubringerweg fьr CA16 und CA17. Nach Rьcksprache mit OAO "Mostostroy" (am / 11.01.2011) wurde der Starttermin auf den 01.03.2011 verschoben.

| ID | WBS | Activity | Duration | Start | Finish | Predecessors | Complete | Total float | Free float | Constraint | Calendar | Resources | Cost | Actual cost | TB26 Ressource Budget | UDF_Weight (ton) | WEIGHT | UDF_CONTRACT INDICATOR | UDF_LEVEL | UDF_PO No | UDF_TAG No | UDF_Object No | UDF_DELIVERY DATE PO | UDF_DELIVERY DATE DISPATCH PLANNED | UDF_DELIVERY DATE TO SITE PLANNED | UDF_DELIVERY DATE SITE NEED DATE | UDF_PACKAGE | UDF_SUPPLIER | UDF_SELECT UPDATE PROGRESS | UDF_SAVE ACT ID | UDF_BUDGETED LABOR UNIT | UDF_ACTUAL LABOR UNIT | Constr. Area | Zeigen/n. Zeigen | WBS Phase | WBS Discipline | WBS Objects | Subcontractor | Department | Type of Work | PMT-Area | PMT-Schedule Org | PMT-Phase | PMT-Respons. | WBS Type of Work | Russia WBS Discipline (Russia) | Russia Construction Area | Russia WBS Phase | IMS | UPT | Russia WBS Objects | POSITION | UDF_COMMENTS | UDF_CONTRACT START DATE | UDF_CONTRACT FINISH DATE | UDF_CONTRACT ITEM | UDF_PLANNED START | UDF_PLANNED FINISH | TB26 Semantics | TB26 Material Res Values | UDF_ELECTRICAL START | UDF_ELECTRICAL FINISH | UDF_CHECK BASELINE | Filter | UDF_CONTRACT FINISH DATE REV1 | UDF_CONTRACT START DATE REV1 | UDF_Vendor Representatives | UDF_SELECT |
| --- | --- | --- | --- | --- | --- | --- | --- | --- | --- | --- | --- | --- | --- | --- | --- | --- | --- | --- | --- | --- | --- | --- | --- | --- | --- | --- | --- | --- | --- | --- | --- | --- | --- | --- | --- | --- | --- | --- | --- | --- | --- | --- | --- | --- | --- | --- | --- | --- | --- | --- | --- | --- | --- | --- | --- | --- | --- | --- | --- | --- | --- | --- | --- | --- | --- | --- | --- | --- |
|  | N | **Structural Steel** |  |  |  |  |  |  |  |  |  |  |  |  |  |  |  |  |  |  |  |  |  |  |  |  |  |  |  |  |  |  |  |  |  |  |  |  |  |  |  |  |  |  |  |  |  |  |  |  |  |  |  |  |  |  |  |  |  |  |  |  |  |  |  |  |  |  |
|  | H | **HVAC** |  |  |  |  |  |  |  |  |  |  |  |  |  |  |  |  |  |  |  |  |  |  |  |  |  |  |  |  |  |  |  |  |  |  |  |  |  |  |  |  |  |  |  |  |  |  |  |  |  |  |  |  |  |  |  |  |  |  |  |  |  |  |  |  |  |  |
|  | U | **Package Units** |  |  |  |  |  |  |  |  |  |  |  |  |  |  |  |  |  |  |  |  |  |  |  |  |  |  |  |  |  |  |  |  |  |  |  |  |  |  |  |  |  |  |  |  |  |  |  |  |  |  |  |  |  |  |  |  |  |  |  |  |  |  |  |  |  |  |
|  | B | **Mechanical - Stationary Equipment** |  | 2011-08-08 | 2012-01-11 |  |  |  |  |  |  |  |  |  |  |  |  |  |  |  |  |  |  |  |  |  |  |  |  |  |  |  |  |  |  |  |  |  |  |  |  |  |  |  |  |  |  |  |  |  |  |  |  |  |  |  |  |  |  |  |  |  |  |  |  |  |  |  |
| V-24101 |  | INSTRUMENT AIR BUFFER TANK | 5d | 2011-08-08 A | 2011-08-12 A | XB001510 SS | 100% |  |  |  |  | Static Equipment > 10 tons [20 t]; Static equipment >10t [1500 h] | 60,000 |  | 1500,00 | 20 | 20000 | UDF_G4 | concrete +0.00 | 2 DC 9450 | V-24101 | SK1510 | 2010-12-31 | 2011-01-15 | 2011-01-30 | 2011-02-18 | A02A LARGE DRUMS (V-21701/24101/21901) | Tambovskij Zavod | 27.8. | V-24101 | 1500 | 0 | 15 | EQ | X | B | 1510 | VNZM |  |  |  |  |  |  |  |  |  |  |  |  |  |  |  |  |  |  |  |  |  |  |  |  |  |  |  |  |  |  |
| XB001510 |  | CA15 Air Buffer - Install Static Eqpt | 5d | 2011-08-08 A | 2011-08-12 A | P3A02S5 (other project), XC201510, XC911510 FF+51d, ER291500 (other project) FS+40d | 100% |  |  | start on or after 2011-08-08 | TB26 - V - Construct-Winter partly * |  |  |  | 20 |  |  | UDF_G4 |  |  |  |  |  |  |  |  |  |  | 27.8. | XB001510 | 0 | 0 | 15 |  | X | B | 1510 | OMUS-1 | 934 | XBB | 200 | 200 | C | LND | XB00 | B | 15 | X | EQ | LND | 1510 |  |  |  |  |  |  |  |  |  |  |  |  |  |  |  |  |  |
| XX-21701 |  | POLYMER WATER BASKET | 10d | 2011-12-23 | 2012-01-11 | XB00171005 SS, XB00171005 FF, SU-21701, P3A02BS (other project) |  | -27.88d | 0d |  |  | Static Equipment < 10 tons [2 t]; Static equipment < 10t [200 h] | 8,000 |  | 200,00 | 2 | 2000 |  |  | 2 DC 9840 | XX-21701 | SK1510 | 2011-03-01 | 2011-03-06 | 2011-04-20 | 2011-03-10 | A02B POLYMER WATER BASKET | Jentec |  | XX-21701 | 200 | 0 | 17 | EQ | X | B | 1710 |  |  |  |  |  |  |  |  |  |  |  |  |  |  | a | in SU-21701 |  |  |  |  |  |  |  |  |  |  |  |  |  |  |  |
|  | M | **Mechanical - Rotating Equipment** |  | 2011-10-19 | 2011-12-05 |  |  |  |  |  |  |  |  |  |  |  |  |  |  |  |  |  |  |  |  |  |  |  |  |  |  |  |  |  |  |  |  |  |  |  |  |  |  |  |  |  |  |  |  |  |  |  |  |  |  |  |  |  |  |  |  |  |  |  |  |  |  |  |
| XM101510 |  | CA15 Air Buffer - Install Rotating Eqpt | 30d | 2011-10-19 | 2011-12-05 | P3M15S1 (other project), P3M14S1 (other project), ER291500 (other project) FS+40d, XC201510 |  | 59d | 0d |  | TB26 - V - Construct-Winter partly * |  |  |  | 1 |  |  | UDF_G3 |  |  |  |  |  |  |  |  |  |  |  | XM101510 | 0 | 0 | 15 |  | X | M | 1510 |  | 934 | XBB | 200 | 200 | C | LND | XM20 | M | 15 | X | EQ | LND | 1510 |  |  |  |  |  |  |  |  |  |  |  |  |  |  |  |  |  |
|  | R | **Piping** |  | 2011-10-25 | 2012-03-15 |  |  |  |  |  |  |  |  |  |  |  |  |  |  |  |  |  |  |  |  |  |  |  |  |  |  |  |  |  |  |  |  |  |  |  |  |  |  |  |  |  |  |  |  |  |  |  |  |  |  |  |  |  |  |  |  |  |  |  |  |  |  |  |
| XR201510 |  | CA15 Air Buffer - Piping Prefabrication | 15d | 2011-10-25 | 2011-11-11 | ER491510 (other project), XB001510 FS-10d |  | 98d | 0d | as late as possible |  | A/G piping prefabrication [110 Fpi]; A/G Piping (Prefab) [412.5 h] | 550.62 |  | 412,50 |  |  |  |  |  |  |  |  |  |  |  |  |  |  | XR201510 | 412,5 | 0 | 15 |  | X | R | 1510 |  | 934 |  | 200 | 200 | C | LND | XR20 | R | 15 | X | PRP | LND | 1510 |  |  |  |  |  |  |  |  |  |  |  |  |  |  |  |  |  |
| XR401510 |  | CA15 Air Buffer - Piping Installation | 30d | 2011-10-31 | 2011-12-27 | P-23801, V-24101, XR201510 FS-10d, SU-23601, P3J04IS (other project), P-23601A/B, IMS-C-000190 FF, P3J04CS1 (other project) |  | 56d | 0d |  | TB26 - V - Construct-Winter partly * | A/G piping field installation [150 Fpi]; Control & Shut-off valves [5 pcs]; Install Control & Shut-off Valves [26.25 h]; A/G Piping (Field) [937.5 h] | 3,001.19 |  | 963,75 |  |  |  |  |  |  |  |  |  |  |  |  |  |  | XR401510 | 963,75 | 0 | 15 |  | X | R | 1510 |  | 934 |  | 200 | 200 | C | LND | XR40 | R | 15 | X | PI | LND | 1510 |  |  | 2011-04-30 | 2011-07-25 | E-06-03-06 | 2011-07-05 |  |  |  |  |  |  |  |  |  |  |  |
| XR601510 |  | CA15 Air Buffer - Piping Pressure Tests | 5d | 2012-03-01 | 2012-03-07 | X0300020, XR401510 |  | 31d | 0d |  | TB26 - T - Construct-Winter-3 (Dec/Jan/Feb free) * |  |  |  | 51 |  |  |  |  |  |  |  |  |  |  |  |  |  |  | XR601510 | 0 | 0 | 15 |  | X | R | 1510 |  | 934 |  | 200 | 200 | C | LND | XR60 | R | 15 | X | HY | LND | 1510 |  |  | 2011-04-30 | 2011-07-25 | E-06-03-06 |  |  |  |  |  |  |  |  |  |  |  |  |
| XR801510 |  | CA15 Air Buffer - Piping Reinstatement | 5d | 2012-03-09 | 2012-03-15 | IMS-C-000360 FF, XR601510 FF+5d |  | 31d | 0d |  | TB26 - V - Construct-Winter partly * |  |  |  | 26 |  |  |  |  |  |  |  |  |  |  |  |  |  |  | XR801510 | 0 | 0 | 15 |  | X | R | 1510 |  | 934 |  | 200 | 200 | C | LND | XR80 | R | 15 | X | PI | LND | 1510 |  |  | 2011-04-30 | 2011-07-25 | E-06-03-06 |  | 2011-09-24 |  |  |  |  |  |  |  |  |  |  |
|  | E | **Electrical** |  | 2011-05-14 | 2012-07-30 |  |  |  |  |  |  |  |  |  |  |  |  |  |  |  |  |  |  |  |  |  |  |  |  |  |  |  |  |  |  |  |  |  |  |  |  |  |  |  |  |  |  |  |  |  |  |  |  |  |  |  |  |  |  |  |  |  |  |  |  |  |  |  |
| XC911510 |  | CA15 Air Buffer - Install Earthing&Lightn.Sys_CIVIL | 10d | 2011-05-14 A | 2011-05-25 A | EE901510 (other project), IMS-C-000230 FF, XC201510 FF+5d | 100% |  |  |  | TB26 - V - Construct-Winter partly * | Grounding & Lightning [100 pcs]; Grounding & Lightning [1125 h] | 45,000 | 45,000 | 1125,00 |  |  |  |  |  |  |  |  |  |  |  |  |  |  | XC911510 | 1125 | 1125 | 15 |  | X | C | 1510 | MO11 | 934 |  | 200 | 200 | C | LND | XE91 | C | 15 | X | EA | LND | 1510 |  |  |  |  |  |  |  |  |  |  |  |  |  |  |  |  |  |
| XE911511 |  | CA15 Air Buffer - Install Earthing&Lightn.Sys_E/I | 5d | 2011-10-31 | 2011-11-07 | V-24101, P-23601A/B, P-23801, SU-23601 |  | 146d | 171d |  | TB26 - V - Construct-Winter partly * |  |  |  | 115 |  |  | UDF_G3 |  |  |  |  |  |  |  |  |  |  |  | XE911511 | 0 | 0 | 15 |  | X | E | 1510 | URMA | 934 |  | 200 | 200 | C | LND | XE91 | E | 15 | X | EA | LND | 1510 |  |  |  |  |  |  |  |  |  |  |  |  |  |  |  |  |  |
| XE401510 |  | CA15 Air Buffer - Install Cable Trays | 30d | 2011-11-16 | 2012-01-25 | XR401510 SS+10d |  | 61d | 0d |  | TB26 - V - Construct-Winter partly * | Cable trays/conduits [70 m]; Cable trays [210 h] | 8,400 |  | 210,00 |  |  |  |  |  |  |  |  |  |  |  |  |  |  | XE401510 | 210 | 0 | 15 |  | X | E | 1510 | URMA | 934 |  | 200 | 200 | C | LND | XE40 | E | 15 | X | EL | LND | 1510 |  |  |  |  |  |  |  | m | 300 | 2011-09-13 | 2011-10-17 | x |  |  |  |  |  |
| XE701500 |  | CA15 Air Buffer - Install Lighting & Small Power | 25d | 2012-01-26 | 2012-02-24 | XE401510, XE705101 SS+10d, P3E09S (other project), XP341610 FS+50d, EE761510 (other project) |  | 105d | 55d |  |  | Cable Pulling [1500 m]; Lighting illuminates [150 pcs]; Lighting (iluminates) [1500 h]; Cable pulling [750 h] | 90,000 |  | 2250,00 |  |  |  |  |  |  |  |  |  |  |  |  |  |  | XE701500 | 2250 | 0 | 15 |  | X | E | 1510 | URMA | 934 |  | 200 | 200 | C | LND | XE70 | E | 15 | X | EL | LND | 1510 |  |  | 2011-05-10 | 2012-01-31 | E-16-03-01 |  |  |  |  |  |  |  | x | 2012-05-10 | 2011-08-15 |  |  |
| XE341510 |  | CA15 Air Buffer - Install Local Operation Panels | 10d | 2012-01-30 | 2012-02-20 | XE401510, XR401510 SS+15d, V-24101, SU-23601, P-23801, P-23601A/B |  | 71d | 96d |  | TB26 - V - Construct-Winter partly * | Field Panels [1 pcs]; Field panels [20 h] | 800 |  | 20,00 |  |  | UDF_G3 |  |  |  |  |  |  |  |  |  |  |  | XE341510 | 20 | 0 | 15 |  | X | E | 1510 | URMA | 934 |  | 200 | 200 | C | LND | XE34 | E | 15 | X | EL | LND | 1510 |  |  |  |  |  |  |  |  |  |  |  |  |  |  |  |  |  |
| XE801510 |  | CA15 Air Buffer - Install Heat Tracing | 15d | 2012-03-09 | 2012-03-29 | E3E1950 (other project), XW501510 FF+5d, P3E19S (other project), XR401510, XR601510 |  | 97d | 0d |  | TB26 - V - Construct-Winter partly * | Electrical Heat Tracing [1400 m]; Electrical heat tracing [700 h] | 28,000 |  | 700,00 |  |  | UDF_G3 |  |  |  |  |  |  |  |  |  |  |  | XE801510 | 700 | 0 | 15 |  | X | E | 1510 | URMA | 934 |  | 200 | 200 | C | LND | XE80 | E | 15 | X | HT | LND | 1510 |  |  | 2011-06-20 | 2012-03-20 | E-16-04-01 |  |  |  |  |  |  |  |  | 2012-06-30 | 2011-09-15 | 005 |  |
| XE201510 |  | CA15 Air Buffer - Install Emergency Diesel Generator | 30d | 2012-05-02 | 2012-06-06 | XC911510, XE401510 SS, P3E14S (other project), P3E22S1 (other project), X3E105 FF, XC201602, XC510C00 FS+15d |  | -24d | 0d |  |  | Main Equipment Substations [1 pcs]; Installation main equipment substation [37.5 h] | 1,500 |  | 37,50 |  |  |  |  |  |  |  |  |  |  |  |  |  |  | XE201510 | 37,5 | 0 | 15 |  | X | E | 1510 | URMA | 934 |  | 200 | 200 | C | LND | XE20 | E | 15 | X | E&I | LND | 1510 |  |  |  |  |  |  |  |  |  |  |  |  |  |  |  |  | REL XC50 |
| XE921500 |  | CA15 Air Buffer - Install Fire Detection System | 20d | 2012-05-02 | 2012-05-25 | XJ421510, XE701500, XC201602, XC510C00 FS+15d |  | 261.5d | 0d |  |  | Fire Detection System; Fire detection system |  |  | 0,00 |  |  |  |  |  |  |  |  |  |  |  |  |  |  | XE921500 | 0 | 0 | 15 |  | X | E | 1510 |  | 934 |  | 200 | 200 | C | UIO | XE92 | E | 15 | X | FGDS | LND | 1510 |  |  |  |  |  |  |  |  |  |  |  | x | x |  |  |  |  |
| XE961500 |  | CA15 Air Buffer - Install Communication System | 20d | 2012-05-02 | 2012-05-25 | XE921500 SS, XE701500, XJ421510, XC201602, XC510C00 FS+15d |  | 261.5d |  |  |  | Communication System |  |  | 0,00 |  |  |  |  |  |  |  |  |  |  |  |  |  |  | XE961500 | 0 | 0 | 15 |  | X | E | 1510 |  | 934 |  | 200 | 200 | C | LND | XE96 | E | 15 | X | CS | LND | 1510 |  |  |  |  |  |  |  |  |  |  |  | x | x |  |  |  |  |
| XE501510 |  | CA15 Air Buffer - Cable Pulling Electric | 30d | 2012-06-07 | 2012-07-12 | XE201510, P3E15BS (other project) FF+20d, EE561920 (other project), XE401510, P3E15AS (other project), XE500C01, P3E15CS (other project), XE505401 SS+5d |  | -25d | 0d |  | TB26 - V - Construct-Winter partly * | Cable Pulling [2200 m]; Cable pulling [1100 h] | 44,000 |  | 1100,00 |  |  | UDF_G3 |  |  |  |  |  |  |  |  |  |  |  | XE501510 | 1100 | 0 | 15 |  | X | E | 1510 | URMA | 934 |  | 200 | 200 | C | LND | XE50 | E | 15 | X | EL | LND | 1510 |  |  | 2011-05-20 | 2012-02-10 | E-16-01-01 |  |  | m | 2300 | 2011-10-18 | 2012-04-11 |  |  | 2012-07-01 | 2011-10-01 |  |  |
| XE601510 |  | CA15 Air Buffer - Cable Termination & Testing | 30d | 2012-06-26 | 2012-07-30 | XE501510 FF+15d, XE341510, P-23601A/B, P-23801, SU-23601, V-24101 |  | -25d | 0d |  |  | Cable connecting [30 pcs]; Cable connecting [75 h] | 3,000 |  | 75,00 |  |  | UDF_G3 |  |  |  |  |  |  |  |  |  |  |  | XE601510 | 75 | 0 | 15 |  | X | E | 1510 | URMA | 934 |  | 200 | 200 | C | LND | XE60 | E | 15 | X | ET | LND | 1510 |  |  | 2011-04-20 | 2011-11-30 | E-16-02-01 |  |  |  |  |  |  |  |  | 2012-08-14 | 2011-12-10 |  |  |

Notes:
- XE201510: Current Status: Container mit dem Emergency Diesel Generator wird von URMA / auf die Fundamente gesetzt und angeschlossen.

| ID | WBS | Activity | Type | Duration | Start | Finish | Predecessors | Complete | Planned start | Planned finish | Total float | Free float | Constraint | Calendar | Resources | Cost | Actual cost | TB26 Ressource Budget | UDF_SAVE ACT ID | UDF_BUDGETED LABOR UNIT | UDF_ACTUAL LABOR UNIT | Department | Constr. Area | PMT-Area | PMT-Schedule Org | PMT-Phase | PMT-Respons. | WBS Phase | WBS Discipline | WBS Type of Work | WBS Objects | Russia WBS Discipline (Russia) | Russia Construction Area | Russia WBS Phase | IMS | UPT | Russia WBS Objects | Subcontractor | Filter | TB26 Semantics | TB26 Material Res Values | UDF_ELECTRICAL START | UDF_ELECTRICAL FINISH | UDF_CHECK BASELINE | UDF_CONTRACT INDICATOR | UDF_CONTRACT START DATE | UDF_CONTRACT FINISH DATE | UDF_CONTRACT ITEM | UDF_CONTRACT FINISH DATE REV1 | UDF_CONTRACT START DATE REV1 | UDF_PENALIZED FINISH | UDF_Text4 | UDF_CHECK CRITICAL PATH | Type of Work | Inquiry/Order No | Zeigen/n. Zeigen | suspend date | resume date | UDF_SELECT UPDATE PROGRESS | UDF_CHECK RESOURCE DATES | Civil item | 4 week lookahead | UDF_Concrete | UDF_BASELINE DEVELOPMENT | Check ResLoading | UDF_SELECT |
| --- | --- | --- | --- | --- | --- | --- | --- | --- | --- | --- | --- | --- | --- | --- | --- | --- | --- | --- | --- | --- | --- | --- | --- | --- | --- | --- | --- | --- | --- | --- | --- | --- | --- | --- | --- | --- | --- | --- | --- | --- | --- | --- | --- | --- | --- | --- | --- | --- | --- | --- | --- | --- | --- | --- | --- | --- | --- | --- | --- | --- | --- | --- | --- | --- | --- | --- |
|  | J | **Instrumentation** |  |  | 2011-11-24 | 2012-09-18 |  |  |  |  |  |  |  |  |  |  |  |  |  |  |  |  |  |  |  |  |  |  |  |  |  |  |  |  |  |  |  |  |  |  |  |  |  |  |  |  |  |  |  |  |  |  |  |  |  |  |  |  |  |  |  |  |  |  |  |  |
| XJ321510 |  | CA15 Air Buffer - Install Junction Boxes |  | 10d | 2011-11-24 | 2011-12-14 | XR401510 SS+15d, P-23801 FF+5d, P-23601A/B FF+5d, P3J06FS (other project), EJ321510 (other project), SU-23601 FF+5d, P3J06ES (other project) FS+14d |  |  |  | 69d | 8d |  | TB26 - V - Construct-Winter partly * | Junction Boxes/Cabinets/Panels [12 pcs]; Install Junction Boxes/ Cabinets/ Panels [300 h] | 12,000 |  | 300,00 | XJ321510 | 300 | 0 | 934 | 15 | 200 | 200 | C | LND | X | J | XJ32 | 1510 | J | 15 | X | IN | LND | 1510 | URMA |  |  |  |  |  |  |  |  |  |  |  |  |  |  |  |  |  |  |  |  |  |  |  |  |  |  |  |  |
| XJ421510 |  | CA15 Air Buffer - Install Secondary Cable Trays |  | 20d | 2011-12-06 | 2012-01-25 | XJ321510 FF+7d, EJ46192010 (other project), XE401510 FF, XR401510 SS+15d, V-24101, P-23601A/B, P-23801, SU-23601 |  |  |  | 61d | 0d |  | TB26 - V - Construct-Winter partly * | Secondary cable trays [50 m]; Install secondary cable trays [187.5 h] | 7,500 |  | 187,50 | XJ421510 | 187,5 | 0 | 934 | 15 | 200 | 200 | C | LND | X | J | XJ42 | 1510 | J | 15 | X | IN | LND | 1510 | URMA | x | m | 150 | 2011-09-13 | 2011-10-17 | x |  |  |  |  |  |  |  |  |  |  |  |  |  |  |  |  |  |  |  |  |  |  |
| XJ441510 |  | CA15 Air Buffer - Install Conduits to Instrm |  | 15d | 2012-01-26 | 2012-02-11 | XJ321510, V-24101, P-23601A/B, P-23801, SU-23601, XR401510 SS+15d, XE401510, XJ421510 |  |  |  | 80d | 19d |  |  |  |  |  |  | XJ441510 | 0 | 0 | 934 | 15 | 200 | 200 | C | LND | X | J | XJ44 | 1510 | J | 15 | X | IN | LND | 1510 | URMA |  |  |  |  |  |  |  |  |  |  |  |  |  |  |  |  |  |  |  |  |  |  |  |  |  |  |  |  |
| XJ301510 |  | CA15 Air Buffer - Install Field Instruments |  | 20d | 2012-02-08 | 2012-03-15 | P3J05S (other project), XR801510 FF, P3J07AS (other project), P3J12AS (other project), EJ361510 (other project), XR401510 SS+15d, V-24101, P-23601A/B, P-23801, SU-23601 |  |  |  | 31d | 0d |  | TB26 - V - Construct-Winter partly * | Field Instruments [50 pcs]; Install field instruments [275 h] | 11,000 |  | 275,00 | XJ301510 | 275 | 0 | 934 | 15 | 200 | 200 | C | LND | X | J | XJ30 | 1510 | J | 15 | X | IN | LND | 1510 | URMA |  |  |  |  |  |  | UDF_G3 |  |  |  |  |  |  |  |  |  |  |  |  |  |  |  |  |  |  |  |  |  |
| XJ541510 |  | CA15 Air Buffer - Pulling Singlecore Cables |  | 20d | 2012-03-01 | 2012-03-29 | XJ421510, EJ801510 (other project), XJ441510 SS+10d, XJ301510 FF+10d, XE500C01 |  |  |  | 66d | 35d |  | TB26 - V - Construct-Winter partly * | Singlecore cables [1500 m]; Pull singlecore cables [1125 h] | 45,000 |  | 1125,00 | XJ541510 | 1125 | 0 | 934 | 15 | 200 | 200 | C | LND | X | J | XJ54 | 1510 | J | 15 | X | IN | LND | 1510 | URMA |  | m | 1435 | 2012-03-01 | 2012-03-29 |  |  |  |  |  |  |  |  |  |  |  |  |  |  |  |  |  |  |  |  |  |  |  |
| XJ701510 |  | CA15 Air Buffer - Instrument Tubing |  | 15d | 2012-03-05 | 2012-03-22 | XJ301510 FF+5d, XR401510 |  |  |  | 63d | 32d |  |  |  |  |  |  | XJ701510 | 0 | 0 | 934 | 15 | 200 | 200 | C | LND | X | J | XJ70 | 1510 | J | 15 | X | IN | LND | 1510 | URMA |  |  |  |  |  |  |  |  |  |  |  |  |  |  |  |  |  |  |  |  |  |  |  |  |  |  |  |  |
| XJ391510 |  | CA15 Air Buffer - Install Earthing Field Eqpt |  | 15d | 2012-04-12 | 2012-04-28 | XJ301510 FS+20d, XJ421510, XJ441510 |  |  |  | 31d | 0d |  |  |  |  |  |  | XJ391510 | 0 | 0 | 934 | 15 | 200 | 200 | C | LND | X | J | XJ39 | 1510 | J | 15 | X | IN | LND | 1510 | URMA |  |  |  |  |  |  |  |  |  |  |  |  |  |  |  |  |  |  |  |  |  |  |  |  |  |  |  |  |
| XJ641510 |  | CA15 Air Buffer - Termin Singlecore Cables |  | 20d | 2012-04-30 | 2012-05-24 | XJ301510, XJ541510 FF+10d, XJ321510, XJ391510, XJ701510 |  |  |  | 31d | 56d |  | TB26 - V - Construct-Winter partly * | Termination Field [705 mhr]; Termination field [705 h] | 70,500 |  | 705,00 | XJ641510 | 705 | 0 | 934 | 15 | 200 | 200 | C | LND | X | J | XJ64 | 1510 | J | 15 | X | IN | LND | 1510 | URMA |  |  |  |  |  |  |  |  |  |  |  |  |  |  |  |  |  |  |  |  |  |  |  |  |  |  |  |  |
| XJ521510 |  | CA15 Air Buffer - Pulling Multicore Cables |  | 20d | 2012-05-29 | 2012-06-22 | XJ525101 SS+10d, XE500C01, XJ321510 SS+15d, XJ525401 SS+10d, XE401510 |  |  |  | 2.5d | 0d |  | TB26 - V - Construct-Winter partly * | Multicore cables [1300 m]; Pull multicore cables [650 h] | 26,000 |  | 650,00 | XJ521510 | 650 | 0 | 934 | 15 | 200 | 200 | C | LND | X | J | XJ52 | 1510 | J | 15 | X | IN | LND | 1510 | URMA |  | m | 950 | 2011-10-29 | 2011-11-30 |  |  | 2011-05-20 | 2012-03-10 | E-17-01-01 | 2012-06-16 | 2011-11-01 |  |  |  |  |  |  |  |  |  |  |  |  |  |  |  |  |
| XJ621510 |  | CA15 Air Buffer - Termin Multicore Cables |  | 15d | 2012-06-09 | 2012-06-28 | XJ321510, XJ521510 FF+5d |  |  |  | 2.5d | 27.5d |  | TB26 - V - Construct-Winter partly * | Termination Field [705 mhr]; Termination field [705 h] | 70,500 |  | 705,00 | XJ621510 | 705 | 0 | 934 | 15 | 200 | 200 | C | LND | X | J | XJ62 | 1510 | J | 15 | X | IN | LND | 1510 | URMA |  |  |  |  |  |  |  | 2011-05-20 | 2012-03-10 | E-17-01-01 | 2012-06-16 | 2011-11-01 |  |  |  |  |  |  |  |  |  |  |  |  |  |  |  |  |
| XJ801510 |  | CA15 Air Buffer - Inspections/ Mech. Acceptance/ Loop Checks |  | 20d | 2012-08-25 | 2012-09-18 | EJ801510 (other project), XJ701510, XJ641510, XJ391510 SS+10d, X3J120, XJ800C00 SS, X030410030, XE601510 |  |  |  | -20.5d | 0d |  | TB26 - V - Construct-Winter partly * | Loop Checks [50 pcs]; Loop checks [250 h] | 10,000 |  | 250,00 | XJ801510 | 250 | 0 | 934 | 15 | 200 | 200 | C | LND | X | J | XJ80 | 1510 | J | 15 | X | LT | LND | 1510 | URMA |  |  |  |  |  |  |  | 2011-06-10 | 2012-04-30 | E-17-02-01 | 2012-08-18 | 2012-03-01 | 2012-08-18 |  |  |  |  |  |  |  |  |  |  |  |  |  |  |  |
|  | S | **Safety & Environment** |  |  |  |  |  |  |  |  |  |  |  |  |  |  |  |  |  |  |  |  |  |  |  |  |  |  |  |  |  |  |  |  |  |  |  |  |  |  |  |  |  |  |  |  |  |  |  |  |  |  |  |  |  |  |  |  |  |  |  |  |  |  |  |  |
|  | W | **Painting** |  |  | 2012-03-17 | 2012-03-22 |  |  |  |  |  |  |  |  |  |  |  |  |  |  |  |  |  |  |  |  |  |  |  |  |  |  |  |  |  |  |  |  |  |  |  |  |  |  |  |  |  |  |  |  |  |  |  |  |  |  |  |  |  |  |  |  |  |  |  |  |
| XW501510 |  | CA15 Air Buffer - Surf.Protection Piping |  | 5d | 2012-03-17 | 2012-03-22 | XR201510 SS, XR801510 FF+5d |  |  |  | 99d | 1d |  |  | Piping painting [64 sqm]; Piping painting [160 h] | 536.58 |  | 160,00 | XW501510 | 160 | 0 | 934 | 15 | 200 | 200 | C | LND | X | W | XW50 | 1510 | W | 15 | X | PA | LND | 1510 |  |  |  |  |  |  |  |  |  |  |  |  |  |  |  |  |  |  |  |  |  |  |  |  |  |  |  |  |  |
|  | V | **Insulation** |  |  | 2012-03-16 | 2012-04-30 |  |  |  |  |  |  |  |  |  |  |  |  |  |  |  |  |  |  |  |  |  |  |  |  |  |  |  |  |  |  |  |  |  |  |  |  |  |  |  |  |  |  |  |  |  |  |  |  |  |  |  |  |  |  |  |  |  |  |  |  |
| XV301510 |  | CA15 Air Buffer -Insulation equipment |  | 30d | 2012-03-16 | 2012-04-23 | XR401510, XE801510 SS+5d |  |  |  | 97d | 0d |  | TB26 - T - Construct-Winter-3 (Dec/Jan/Feb free) * | Equipment insulation [100 sqm]; Equipment insulation [1250 h] |  |  | 1250,00 | XV301510 | 1250 | 0 | 934 | 15 | 200 | 200 | C | LND | X | V | XV30 | 1510 | V | 15 | X | INS | LND | 1510 |  |  |  |  |  |  |  |  |  | 2012-03-30 | E-13-03 |  |  |  |  |  |  |  |  |  |  |  |  |  |  |  |  |  |  |
| XV501510 |  | CA15 Air Buffer - Insulation Piping |  | 30d | 2012-03-26 | 2012-04-30 | XW501510 FF+20d, XR601510 SS+10d, XE801510 FF+20d, XV301510 FF+6d |  |  |  | 97d | 117.5d |  | TB26 - T - Construct-Winter-3 (Dec/Jan/Feb free) * | Piping insulation [60 sqm]; Piping insulation [450 h] |  |  | 450,00 | XV501510 | 450 | 0 | 934 | 15 | 200 | 200 | C | LND | X | V | XV50 | 1510 | V | 15 | X | INS | LND | 1510 |  |  |  |  |  |  |  |  |  | 2012-04-30 | E-13-01 |  |  |  |  |  |  |  |  |  |  |  |  |  |  |  |  |  |  |
|  | 11 | **CA15 - Sanitary Lifting Station Section** |  |  |  |  |  |  |  |  |  |  |  |  |  |  |  |  |  |  |  |  |  |  |  |  |  |  |  |  |  |  |  |  |  |  |  |  |  |  |  |  |  |  |  |  |  |  |  |  |  |  |  |  |  |  |  |  |  |  |  |  |  |  |  |  |
|  | 16 | **CA16 - Substation** |  |  | 2008-09-24 | 2012-12-16 |  |  |  |  |  |  |  |  |  |  |  |  |  |  |  |  |  |  |  |  |  |  |  |  |  |  |  |  |  |  |  |  |  |  |  |  |  |  |  |  |  |  |  |  |  |  |  |  |  |  |  |  |  |  |  |  |  |  |  |  |
|  | 00 | **CA16 - General** |  |  | 2012-12-16 | 2012-12-16 |  |  |  |  |  |  |  |  |  |  |  |  |  |  |  |  |  |  |  |  |  |  |  |  |  |  |  |  |  |  |  |  |  |  |  |  |  |  |  |  |  |  |  |  |  |  |  |  |  |  |  |  |  |  |  |  |  |  |  |  |
|  | 0B | **General Activities** |  |  | 2012-12-16 | 2012-12-16 |  |  |  |  |  |  |  |  |  |  |  |  |  |  |  |  |  |  |  |  |  |  |  |  |  |  |  |  |  |  |  |  |  |  |  |  |  |  |  |  |  |  |  |  |  |  |  |  |  |  |  |  |  |  |  |  |  |  |  |  |
| X0101600 |  | CA16 General - Mechanical Completion, Loop Checks ongoing | milestone | 0d | 2012-12-16 | 2012-12-16 | XH00161015, XE600C10, XH00161010, XE50161015, XC601600 FF, XC50161005, XV501610, XE701600, XJ304100 FF, XC301600, XE341610, XJ611610, XR801600, XE50161010, XJ301610 FF, XE60161005, XJ801610, XC301610 |  |  |  | -113.5d | 13d |  | TB26 - 2 - Manuf and Delivy |  |  |  |  | X0101600 | 0 | 0 | 934 | 16 | 200 | 200 | C | LND | X | 0B | X010 | 1600 | 0 | 16 | X | MC | LND | 1600 |  |  |  |  |  |  |  |  |  |  |  |  |  |  | CA16 - critical - CW05 | XC301600 | XNK |  |  |  |  |  |  |  |  |  |  |  |  |
|  | 04 | **CA16 - Auxiliary Structures** |  |  |  |  |  |  |  |  |  |  |  |  |  |  |  |  |  |  |  |  |  |  |  |  |  |  |  |  |  |  |  |  |  |  |  |  |  |  |  |  |  |  |  |  |  |  |  |  |  |  |  |  |  |  |  |  |  |  |  |  |  |  |  |  |
|  | 10 | **CA16 - Substation / RIE's** |  |  | 2008-09-24 | 2012-12-16 |  |  |  |  |  |  |  |  |  |  |  |  |  |  |  |  |  |  |  |  |  |  |  |  |  |  |  |  |  |  |  |  |  |  |  |  |  |  |  |  |  |  |  |  |  |  |  |  |  |  |  |  |  |  |  |  |  |  |  |  |
|  | C | **Civil Work** |  |  | 2008-09-24 | 2012-08-22 |  |  |  |  |  |  |  |  |  |  |  |  |  |  |  |  |  |  |  |  |  |  |  |  |  |  |  |  |  |  |  |  |  |  |  |  |  |  |  |  |  |  |  |  |  |  |  |  |  |  |  |  |  |  |  |  |  |  |  |  |
| XC111600 |  | CA16 Subst&RIE's - Excavation&Surface Prep by U/I/O |  | 294d | 2008-09-24 A | 2009-09-30 A | XC111700 SS | 100% |  |  |  |  |  |  |  |  |  |  | XC111600 | 0 | 0 | 934 | 16 | 200 | 200 | C | UIO | X | C | XC11 | 1610 | C | 16 | X | CW | LND | 1610 | MO11 |  |  |  |  |  |  |  |  |  |  |  |  |  |  |  |  |  |  |  |  |  |  |  |  |  |  |  |  |
| XC11160005 |  | CA16 Subst&RIE's - Excavation |  | 12d | 2010-04-14 A | 2010-04-27 A | XC111600 | 100% |  |  |  |  |  |  | Excavation [10800 cbm]; Excavation [5400 h] | 432,000 | 432,000 | 5400,00 | XC11160005 | 5400 | 5400 | 934 | 16 | 200 | 200 | C | MO02 | X | C | XC11 | 1610 | C | 10 | X | P | LND | 1010 | MO11 |  |  |  |  |  |  |  |  |  |  |  |  |  |  |  |  | 999 | C2 |  |  |  |  |  |  |  |  |  |  |
| XC11160010 |  | CA16 Subst&RIE's - SubBase (Gravel/Geogrid) for Concrete |  | 25d | 2010-04-28 A | 2010-05-28 A | XC11160005 | 100% | 2010-04-28 | 2010-05-27 |  |  |  |  | Sub Base for Concrete/Paving&Roads (Gravel) [1900 cbm]; Subbase for Concrete [1900 h] | 190,000 | 65,000 | 1900,00 | XC11160010 | 1900 | 1900 | 934 | 16 | 200 | 200 | C | MO02 | X | C | XC11 | 1610 | C | 10 | X | P | LND | 1010 | MO11 |  |  |  |  |  |  |  |  |  |  |  |  |  |  |  |  | 999 | C2 |  |  |  |  |  |  |  |  |  |  |
| XC151600 |  | CA16 Subst&RIE's - Piling |  | 17d | 2010-06-21 A | 2010-07-09 A | XC11160010 FS+5d, F2910, EC151610 (other project) FS+10d, XC111600, XC11160005 | 100% |  |  |  |  |  |  | Piles driven [317 pcs]; Piles driven [2377.5 h] | 95,100 | 95,100 | 2377,50 | XC151600 | 2377,5 | 2377,5 | 934 | 16 | 200 | 200 | C | MO02 | X | C | XC15 | 1610 | C | 16 | X | P | LND | 1610 | MO11 |  |  |  |  |  |  |  |  |  |  |  |  |  |  |  |  |  | C2 |  |  |  |  |  |  |  |  |  |  |
| XC40161005 |  | CA16 Subst&RIE's - Concrete Works Bldg Fdtn |  | 55d | 2010-07-12 A | 2010-09-13 A | EC45161005 (other project) SS, P3C02D1 (other project), EC48161003 (other project) FS+9d, EC45161015 (other project), XC151600 SS+18d | 100% |  |  |  |  |  | TB26 - V - Construct-Winter partly * | Concrete works [1550 cbm]; Concrete works [46500 h] | 19,548.88 |  | 46500,00 | XC40161005 | 46500 | 46500 | 934 | 16 | 200 | 200 | C | MO03 | X | C | XC20 | 1610 | C | 16 | X | mai | LND | 1610 | MO11 |  |  |  |  |  |  |  |  |  |  |  |  |  |  |  |  |  | C2 |  |  |  |  |  |  |  |  |  |  |
| XC40161007 |  | CA16 Subst&RIE's - Concrete Works Bldg Fdtn finished | milestone | 0d | 2010-09-13 A | 2010-09-13 A | XC40161005 FF | 100% |  |  |  |  |  | TB26 - V - Construct-Winter partly * |  |  |  |  | XC40161007 | 0 | 0 | 934 | 16 | 200 | 200 | C | MO04 | X | C | XC20 | 1610 | C | 12 | X | mai | LND | 1201 | MO11 |  |  |  |  |  |  |  |  |  |  |  |  |  |  |  |  |  |  |  |  |  |  |  |  |  |  |  |  |
| XC40161010 |  | CA16 Subst&RIE's - Precast Concrete Elements |  | 100d | 2010-09-16 A | 2011-01-19 A | EC48161007 (other project), EC48161006 (other project), EC48161008 (other project) FF, XC40161007, P3C02D2 (other project) FS+37d, EC48161004 (other project) FF, XC151600 FF+20d, EC48161015 (other project) FF+10d | 100% |  |  |  |  |  |  |  |  |  |  | XC40161010 | 0 | 0 | 934 | 16 | 200 | 200 | C | MO04 | X | C | XC40 | 1610 | C | 16 | X | pre | LND | 1610 | MO11 |  |  |  |  |  |  |  |  |  |  |  |  |  |  |  |  |  | C2 |  |  |  |  |  |  |  |  |  |  |
| XC191600 |  | CA16 Subst&RIE's - Backfill |  | 224d | 2010-09-20 A | 2011-08-01 A | IMS-C-000240 FF+20d, XC40161005 FS+5d | 100% | 2010-09-20 | 2011-09-24 |  |  |  | TB26 - T - Construct-Winter-3 (Dec/Jan/Feb free) * | Backfill & Compaction [6000 cbm]; Backfill & Compaction [9000 h] | 540,000 | 540,000 | 9000,00 | XC191600 | 9000 | 9000 | 934 | 16 | 200 | 200 | C | CiC | X | C | XC19 | 1610 | C | 16 | X | UG | LND | 1610 | MO11 |  |  |  |  |  |  |  |  |  |  |  |  |  | CA16 - critical - CW05 |  |  |  |  | 2010-11-01 | 2010-11-30 | 27.8. | x |  |  |  |  |  |  |
| XC401610 |  | CA16 Subst&RIE's - Erection Precast Elements / Concrete Works Ceiling |  | 99d | 2010-10-08 A | 2011-04-07 A | IMS-C-000100 FF, EC48161012 (other project) FF+10d, XC40161010 FF+10d, EC701610 (other project) FF, XC151600, XC200C00 SS, EC48161010 (other project) FF+20d, XC40161005, EC45161005 (other project) FF, EC48161015 (other project) FF+10d | 100% |  |  |  |  |  | TB26 - V - Construct-Winter partly * | Precast Concrete Works [665 cbm]; Concrete works [310 cbm]; Precast concrete works [1662.5 h]; Concrete works [9300 h] | 382,672.43 | 372,000 | 10962,50 | XC401610 | 10962,5 | 10962,5 | 934 | 16 | 200 | 200 | C | MO04 | X | C | XC40 | 1610 | C | 16 | X | SS | LND | 1610 | MO11 |  |  |  |  |  |  |  |  |  |  |  |  |  | CA16 - critical - CW05 |  |  |  | C2 |  |  |  |  | Comp | x |  |  |  |  |
| XC521610 |  | CA16 Subst&RIE's - Cable Trenches |  | 30d | 2011-04-04 A | 2011-05-10 A | XC191605 SS, XC191600 SS | 100% |  |  |  |  | start on or after 2011-04-04 | TB26 - V - Construct-Winter partly * |  |  |  |  | XC521610 | 0 | 0 | 934 | 16 | 200 | 200 | C | CiC | X | C | XC52 | 1610 | C | 16 | X | OB | LND | 1610 | MO11 |  |  |  |  |  |  |  |  |  |  |  |  |  | CA16 - critical - CW05 |  |  |  | C2 |  |  |  |  |  | x |  |  |  |  |
| XC301600 |  | CA16 Subst&RIE's - UG Installation (roof drainage) (incl. Precast Manholes) |  | 38d | 2011-09-05 | 2011-10-18 | XC300C10 SS, P3R02BS (other project) FF+20d, XC40161005 SS+25d, XC300C00, P3R02AS1 (other project) FF, P3R02S1 (other project), ER441600 (other project), XC401610, XC310C00, P3C02D4 (other project) FS+10d, P3R02BS (other project), P3R02AS1 (other project), XC300C00 SS |  |  |  | 178d | 0d |  | TB26 - V - Construct-Winter partly * | Fire water hydrants/monitors [2 pcs]; fire water hydrants/ monitors [125 h]; FRP U/G Piping [25 m]; FRP U/G piping [325 h]; Cast Iron U/G Piping [145 m]; Cast iron U/G piping [2900 h]; Concrete Manholes [30 pcs]; concrete manholes [7625 h]; Floor Drains / Catch Basins [4 pcs]; floor drains / catch basins [100 h] | 467,500 |  | 22000,00 | XC301600 | 11075 | 0 | 934 | 16 | 200 | 200 | C | CiC | X | C | XC30 | 1610 | C | 16 | X | UG | LND | 1610 |  |  |  |  |  |  |  |  |  |  |  |  |  |  | CA16 - critical - CW05 | XC301600 |  |  |  |  |  | 27.8. | ok |  |  | 1 | XC301600 | UG |  |
| XC50161010 |  | CA16 Subst&RIE's - Finishing Works Rooms (incl. Sanitary) 1st Floor |  | 65d | 2011-09-12 | 2011-11-26 | XC401610, IMS-C-000240 FF+20d, IMS-C-000100 FF, XC510C00, EC501610 (other project), XC500C00 SS |  |  |  | -105d | 0d | start on or after 2011-09-05 |  | Finishing Works - Substation CA16 [35035 mhr]; Finishing Works - Substation CA16 [35035 h] | 3,503,500 |  | 32232,00 | XC50161010 | 35035 | 0 | 934 | 16 | 200 | 200 | C | CiC | X | C | XC50 | 1610 | C | 16 | X | SS | LND | 1610 |  |  |  |  |  |  |  |  |  |  |  |  |  |  | CA16 - critical - CW09 |  |  |  | C2 |  |  | 27.8. |  |  |  | 1 |  |  | XC50 |
| XC521600 |  | CA16 Subst&RIE's - False Floor, fabrication material |  | 64.5d | 2011-09-12 | 2011-12-12 |  |  |  |  | -169.5d | 0d | start on or after 2011-09-12 | TB26 - V - Construct-Winter partly * |  |  |  |  | XC521615 | 0 | 0 | 934 | 16 | 200 | 200 | C | CiC | X | C | XC52 | 1610 | C | 16 | X | OB | LND | 1610 |  |  |  |  |  |  |  |  |  |  |  |  |  |  | CA16 - critical - CW05 |  |  |  | C2 |  |  |  |  |  | x |  |  |  | XC50 |
| XC191605 |  | CA16 Subst&RIE's - Backfill |  | 30d | 2011-09-26 | 2011-10-29 | XC301600 FF+10d |  |  |  | 142d | 0d |  | TB26 - T - Construct-Winter-3 (Dec/Jan/Feb free) * | Backfill & Compaction [4000 cbm]; Backfill & Compaction [6000 h] | 360,000 |  | 13500,00 | XC191605 | 6000 | 0 | 934 | 16 | 200 | 200 | C | CiC | X | C | XC19 | 1610 | C | 16 | X | UG | LND | 1610 | MO11 | 1 |  |  |  |  | x |  |  |  |  |  |  |  | CA16 - critical - CW05 | XC301600 |  |  |  | 2010-11-01 | 2010-11-30 |  |  |  |  |  |  | X |  |
| XC50161010_1 |  | CA16 Subst&RIE's - Plastering and Painting (Finishing Works) 1st Floor |  | 20d | 2011-10-05 | 2011-10-27 | XC50161010 SS+20d |  |  |  | 19d | 0d |  |  |  |  |  | 32232,00 | XC50161010 | 35035 | 0 | 934 | 16 | 200 | 200 | C | CiC | X | C | XC50 | 1610 | C | 16 | X | SS | LND | 1610 |  |  |  |  |  |  |  |  |  |  |  |  |  |  | CA16 - critical - CW09 |  |  |  | C2 |  |  | 27.8. |  |  |  | 1 |  |  |  |
| XC50161020 |  | CA16 Subst&RIE's - Finishing Works Rooms (incl. Sanitary) 2nd Floor |  | 65d | 2011-10-11 | 2011-12-26 | XC001600 FF, P3S05S (other project) FF, EC501610 (other project), IMS-C-000100 FF, XC510C00 FS+15d, IMS-C-000240 FF+20d, XC401610, XC50161010 FS-40d, XC500C00 SS |  |  |  | 49d | 0d |  |  | Finishing Works - Substation CA16 [35035 mhr]; Finishing Works - Substation CA16 [35035 h] | 3,503,500 |  | 32232,00 | XC50161020 | 35035 | 0 | 934 | 16 | 200 | 200 | C | CiC | X | C | XC50 | 1610 | C | 16 | X | SS | LND | 1610 |  | x |  |  |  |  |  |  |  |  |  |  |  |  | CA16 - critical - CW05 |  |  |  | C2 |  |  |  |  |  |  | 1 |  |  | XC50 |
| XC50161020_1 |  | CA16 Subst&RIE's - Plastering and Painting (Finishing Works) 2nd Floor |  | 20d | 2011-10-11 | 2011-11-02 | XC50161020 SS |  |  |  | 55d | 0d |  |  |  |  |  | 32232,00 | XC50161020 | 35035 | 0 | 934 | 16 | 200 | 200 | C | CiC | X | C | XC50 | 1610 | C | 16 | X | SS | LND | 1610 |  | x |  |  |  |  |  |  |  |  |  |  |  |  | CA16 - critical - CW05 |  |  |  | C2 |  |  |  |  |  |  | 1 |  |  |  |
| XC601600 |  | CA16 Subst&RIE's - Paving inside / outside |  | 90d | 2011-11-10 | 2012-03-01 | XC191600 FF+20d, XC191605 FF+20d, EC601600 (other project) FS+10d, XC50161010 SS+30d |  |  |  | 147d | 243d |  |  | Concrete paved areas & concrete Roads [1400 sqm]; Concrete paved areas & concrete roads [5250 h] | 4,841.03 |  | 5250,00 | XC601600 | 5250 | 0 | 934 | 16 | 200 | 200 | C | CiC | X | C | XC60 | 1610 | C | 16 | X | PV | LND | 1610 | MO11 |  |  |  |  |  |  |  |  |  |  |  |  |  | CA16 - critical - CW05 |  |  |  |  |  |  |  |  |  |  | 1 |  |  |  |
| XC521605 |  | CA16 Subst&RIE's - False Floor, delivery material |  | 15d | 2011-12-12 | 2012-01-23 | XC521600 |  |  |  | -169.5d | 0d |  | TB26 - V - Construct-Winter partly * |  |  |  |  | XC521615 | 0 | 0 | 934 | 16 | 200 | 200 | C | CiC | X | C | XC52 | 1610 | C | 16 | X | OB | LND | 1610 |  |  |  |  |  |  |  |  |  |  |  |  |  |  | CA16 - critical - CW05 |  |  |  | C2 |  |  |  |  |  | x |  |  |  | XC50 |
| XC50161005 |  | CA16 Subst&RIE's - Punch out & rectification |  | 40d | 2011-12-15 | 2012-02-06 | P3S05S (other project) FF+10d, XC50161020 FS-10d, XC510C00 FS+15d, XC50161010 |  |  |  | 167d | 263d |  |  |  |  |  | 7280,00 | XC50161005 | 0 | 0 | 934 | 16 | 200 | 200 | C | CiC | X | C | XC50 | 1610 | C | 16 | X | SS | LND | 1610 |  |  |  |  |  |  |  |  |  |  |  |  |  |  | CA16 - critical - CW05 |  |  |  | C2 |  |  |  |  |  |  | 1 |  |  |  |
| XC521615 |  | CA16 Subst&RIE's - Install False Floor, structure |  | 20d | 2012-01-23 | 2012-03-05 | XC50161010 SS+15d, XC401610, XN801610 FS-5d, EC521610 (other project), XC521605 |  |  |  | -169.5d | 0d |  | TB26 - V - Construct-Winter partly * |  |  |  |  | XC521615 | 0 | 0 | 934 | 16 | 200 | 200 | C | CiC | X | C | XC52 | 1610 | C | 16 | X | OB | LND | 1610 |  |  |  |  |  |  |  |  |  |  |  |  |  |  | CA16 - critical - CW05 |  |  |  | C2 |  |  |  |  |  | x |  |  |  | XC50 |
| XC201602 |  | SK1602 EDB - Concrete Works Base+Walls (Emergency Diesel Building) |  | 25d | 2012-04-02 | 2012-04-30 | XC151510, EC281510 (other project) FS+10d, XC201510 FS-15d |  |  |  | -24d | 0d | start on or after 2012-04-02 | TB26 - V - Construct-Winter partly * | Concrete works [40 cbm]; Concrete works [1200 h] |  |  | 1200,00 | XC201602 | 1200 | 390 | 934 | 16 | 200 | 200 | C | CiC | X | C | XC20 | 1610 | C | 16 | X | OB | LND | 1510 | MO11 | 1 |  |  |  |  |  |  |  |  |  |  |  |  |  |  |  |  |  |  |  |  |  | x |  |  |  |  |  |
| XC521625 |  | CA16 Subst&RIE's - Install False Floor, panels |  | 20d | 2012-04-10 | 2012-05-04 | XE411620 |  |  |  | -165.5d | 0d |  | TB26 - V - Construct-Winter partly * |  |  |  |  | XC521615 | 0 | 0 | 934 | 16 | 200 | 200 | C | CiC | X | C | XC52 | 1610 | C | 16 | X | OB | LND | 1610 |  |  |  |  |  |  |  |  |  |  |  |  |  |  | CA16 - critical - CW05 |  |  |  | C2 |  |  |  |  |  | x |  |  |  | XC50 |
| XC301610 |  | CA16 Subst&RIE's - UG Installation (incl. Precast Manholes) |  | 50d | 2012-05-02 | 2012-06-30 | XC201602 |  |  |  | 47d | 0d | start on or after 2012-03-01 | TB26 - V - Construct-Winter partly * | Fire water hydrants/monitors [2 pcs]; fire water hydrants/ monitors [125 h]; FRP U/G Piping [25 m]; FRP U/G piping [300 h]; Cast Iron U/G Piping [145 m]; Cast iron U/G piping [2900 h]; Concrete Manholes [25 pcs]; concrete manholes [7500 h]; Floor Drains / Catch Basins [4 pcs]; floor drains / catch basins [100 h] | 412,500 |  | 22000,00 | XC301600 | 10925 | 0 | 934 | 16 | 200 | 200 | C | CiC | X | C | XC30 | 1610 | C | 16 | X | UG | LND | 1610 |  |  |  |  |  |  |  |  |  |  |  |  |  |  | CA16 - critical - CW05 | XC301600 |  |  |  |  |  |  |  |  |  | 1 | XC301600 | UG |  |
| XC191610 |  | CA16 Subst&RIE's - Backfill |  | 45d | 2012-07-02 | 2012-08-22 | XC301610 |  |  |  | 186.5d |  |  | TB26 - T - Construct-Winter-3 (Dec/Jan/Feb free) * | Backfill & Compaction [4000 cbm]; Backfill & Compaction [6000 h] | 360,000 |  | 13500,00 | XC191605 | 6000 | 0 | 934 | 16 | 200 | 200 | C | CiC | X | C | XC19 | 1610 | C | 16 | X | UG | LND | 1610 | MO11 | 1 |  |  |  |  | x |  |  |  |  |  |  |  | CA16 - critical - CW05 | XC301600 |  |  |  | 2010-11-01 | 2010-11-30 |  |  |  |  |  |  | X |  |

Notes:
- XJ541510: Current Status: 04.04.2011 (O.Siegel): Calender geдndert.
- XW501510: P3 Activity Log Info: Clarification Surface Protection during Prefab
- XC111600: P3 Activity Log Info: incl. Dewatering/Drainage
- XC151600: P3 Activity Log Info: 354 dp expected
- XC401610: Current Status: 12.01.2011 (Oxana): Endtermin wurde auf den 31.01.2011 / verschoben (mьndliche Terminabsprache mit OAO "Mostostroy" vom / 11.01.2011)
- XC521610: Current Status: 13.01.2011 (Oxana): laut Aussage von Mostostroy sind noch / kene Zeichnungen vorhanden! Klдrungsbedarf.
- XC301600: P3 Activity Log Info: Clarification Prefab Catch Basins/pulling pits
- XC50161010: Current Status: 12.01.2011 (O. Siegel): nach Rьcksprache mit MO11 am 11 / und 12.Jan 11 wurde als Starttermin der 16-Mai-2011 bespochen
- XC50161010_1: Current Status: 12.01.2011 (O. Siegel): nach Rьcksprache mit MO11 am 11 / und 12.Jan 11 wurde als Starttermin der 16-Mai-2011 bespochen
- XC301610: P3 Activity Log Info: Clarification Prefab Catch Basins/pulling pits

| ID | WBS | Activity | Type | Duration | Start | Finish | Predecessors | Complete | Remaining | Planned start | Planned finish | Total float | Free float | Constraint | Calendar | Resources | Cost | Actual cost | TB26 Ressource Budget | UDF_SAVE ACT ID | UDF_CHECK BASELINE | UDF_BUDGETED LABOR UNIT | UDF_ACTUAL LABOR UNIT | Department | Type of Work | Constr. Area | PMT-Area | PMT-Schedule Org | PMT-Phase | PMT-Respons. | Zeigen/n. Zeigen | WBS Phase | WBS Discipline | WBS Type of Work | WBS Objects | Russia WBS Discipline (Russia) | Russia Construction Area | Russia WBS Phase | IMS | UPT | Russia WBS Objects | UDF_Text4 | UDF_CONTRACT START DATE | UDF_CONTRACT FINISH DATE | UDF_CONTRACT ITEM | TB26 Semantics | UDF_SELECT UPDATE PROGRESS | 4 week lookahead | Subcontractor | UDF_CONTRACT INDICATOR | UDF_CHECK RESOURCE DATES | Filter | UDF_L3 START DATE | UDF_L3 FINISH DATE | UDF_SELECT | UDF_CONTRACT DATE PENALIZED | UDF_PLANNED START | UDF_PLANNED FINISH |
| --- | --- | --- | --- | --- | --- | --- | --- | --- | --- | --- | --- | --- | --- | --- | --- | --- | --- | --- | --- | --- | --- | --- | --- | --- | --- | --- | --- | --- | --- | --- | --- | --- | --- | --- | --- | --- | --- | --- | --- | --- | --- | --- | --- | --- | --- | --- | --- | --- | --- | --- | --- | --- | --- | --- | --- | --- | --- | --- |
|  | N | **Structural Steel** |  |  | 2011-02-01 | 2011-09-16 |  |  |  |  |  |  |  |  |  |  |  |  |  |  |  |  |  |  |  |  |  |  |  |  |  |  |  |  |  |  |  |  |  |  |  |  |  |  |  |  |  |  |  |  |  |  |  |  |  |  |  |  |
| XN701601 |  | CA16 Subst&RIE's SK1601- KMD Assy Drawings (roof beams) | milestone | 0d | 2011-02-01 A | 2011-02-01 A |  | 100% |  |  |  |  |  | finish on 2011-01-22 | TB26 - V - Construct-Winter partly * |  |  |  | 22t | XN701601 | x | 0 | 0 | 934 | XNK | 16 | 200 | 200 | C | LND | KMD | X | N | XN05 | 1610 | N | 16 | X | SS | LND | 1610 |  |  |  |  |  |  |  |  |  |  |  |  |  |  |  |  |  |
| XN711601 |  | CA16 Subst&RIE's SK1601 - Steel Deliveries (roof beams) | milestone | 0d | 2011-02-01 A | 2011-02-01 A |  | 100% |  |  |  |  |  | finish on 2011-01-31 | TB26 - 3 - Construction Normal 7days * CA17 |  |  |  | 22t | XN711601 |  | 0 | 0 | 934 | XNK | 16 | 200 | 200 | C | LND | SD | X | N | XN06 | 1610 | N | 16 | X | SS | LND | 1610 |  |  |  |  |  |  |  |  |  |  |  |  |  |  |  |  |  |
| XN741601 |  | CA16 Subst&RIE's SK1601- KMD Assy Drawings (purlins) | milestone | 0d | 2011-02-01 A | 2011-02-01 A |  | 100% |  |  |  |  |  | finish on 2011-01-22 | TB26 - V - Construct-Winter partly * |  |  |  | 22t | XN741601 | x | 0 | 0 | 934 | XNK | 16 | 200 | 200 | C | LND | KMD | X | N | XN05 | 1610 | N | 16 | X | SS | LND | 1610 |  |  |  |  |  |  |  |  |  |  |  |  |  |  |  |  |  |
| XN751601 |  | CA16 Subst&RIE's SK1601 - Steel Deliveries (purlins) | milestone | 0d | 2011-02-01 A | 2011-02-01 A |  | 100% |  |  |  |  |  | finish on 2011-01-31 | TB26 - 3 - Construction Normal 7days * CA17 |  |  |  | 22t | XN751601 |  | 0 | 0 | 934 | XNK | 16 | 200 | 200 | C | LND | SD | X | N | XN06 | 1610 | N | 16 | X | SS | LND | 1610 |  |  |  |  |  |  |  |  |  |  |  |  |  |  |  |  |  |
| XN721601 |  | CA16 Subst&RIE's SK1601- KMD Assy Drawings (staircґs+platforms) | milestone | 0d | 2011-02-08 A | 2011-02-08 A |  | 100% |  |  |  |  |  | finish on 2011-02-08 | TB26 - V - Construct-Winter partly * |  |  |  | 22t | XN721601 | x | 0 | 0 | 934 | XNK | 16 | 200 | 200 | C | LND | KMD | X | N | XN05 | 1610 | N | 16 | X | SS | LND | 1610 |  |  |  |  |  |  |  |  |  |  |  |  |  |  |  |  |  |
| XN301610 |  | CA16 Subst&RIE's SK1601 - Install Primary Steel |  | 78d | 2011-02-14 A | 2011-05-31 A | XN711600 FF+15d, P3N012D (other project) FS+5d, P3N02BN (other project), XN701601, XN711601 FS+10d, XN751601 FS+10d, XC401610 FS+2d, XN741601 | 100% |  |  |  |  |  |  | TB26 - V - Construct-Winter partly * | Piperacks, Main Structures [137 t]; Piperacks, Main structures [5822.5 h] | 232,900 | 232,900 | 5822,50 | XN301610 |  | 5822,5 | 5822,5 | 934 | XNK | 16 | 200 | 200 | C | LND | C2 | X | N | XN20 | 1610 | N | 16 | X | SS | LND | 1610 | CA16 - critical - CW09 | 2011-01-10 | 2011-02-28 | E-04-09 | t | x | x | ChSK |  |  |  |  |  |  |  |  |  |
| XN731601 |  | CA16 Subst&RIE's SK1601 - Steel Deliveries (staircґs+platforms) | milestone | 0d | 2011-02-15 A | 2011-02-15 A |  | 100% |  |  |  |  |  | finish on 2011-02-15 | TB26 - 3 - Construction Normal 7days * CA17 |  |  |  | 22t | XN731601 |  | 0 | 0 | 934 | XNK | 16 | 200 | 200 | C | LND | SD | X | N | XN06 | 1610 | N | 16 | X | SS | LND | 1610 |  |  |  |  |  |  |  |  |  |  |  |  |  |  |  |  |  |
| XN701600 |  | CA16 General (SK1600) - KMD Assy Drawings | milestone | 0d | 2011-03-31 A | 2011-03-31 A |  | 100% |  |  |  |  |  | finish on 2011-03-31 | TB26 - V - Construct-Winter partly * |  |  |  | 22t | XN701600 | x | 0 | 0 | 934 | XNK | 16 | 200 | 200 | C | LND | KMD | X | N | XN05 | 1600 | N | 16 | X | SS | LND | 1600 | CA16 - critical - CW09 |  |  |  |  |  |  |  |  |  |  |  |  |  |  |  |  |
| XN801610 |  | CA16 Subst&RIE's SK1601 - Cladding Works Walls/Roof |  | 130d | 2011-04-08 A | 2011-09-09 | XN301610 SS+10d, XC401610, P3N03N (other project) | 100% | 12d |  |  | -84d | 0d | start on or after 2011-04-04 | TB26 - V - Construct-Winter partly * | Cladding [3660 sqm]; Cladding [18300 h] | 732,000 | 668,000 | 18300,00 | XN801610 |  | 18300 | 10946,25 | 934 | XNK | 16 | 200 | 200 | C | LND | C2 | X | N | XN80 | 1610 | N | 16 | X | SS | LND | 1710 | CA16 - critical - CW05 |  |  |  |  | 27.8. | x | ChSK | UDF_G4 | actual finish |  |  |  |  |  |  |  |
| XN711600 |  | CA16 General (SK1600) - Steel Deliveries | milestone | 0d | 2011-04-09 A | 2011-04-09 A |  | 100% |  |  |  |  |  | finish on 2011-04-09 | TB26 - 3 - Construction Normal 7days * CA17 |  |  |  | 22t | XN711600 |  | 0 | 0 | 934 | XNK | 16 | 200 | 200 | C | LND | SD | X | N | XN06 | 1600 | N | 16 | X | SS | LND | 1600 | CA16 - critical - CW09 |  |  |  |  |  |  |  |  |  |  |  |  |  |  |  |  |
| XN401610 |  | CA16 Subst&RIE's SK1601 - Install Railings,Ladders,etc. |  | 40d | 2011-08-08 A | 2011-09-16 | XN721601, XN301610 SS+20d, XN731601 FS+10d |  | 18d | 2011-08-29 | 2011-10-13 | 420.5d |  |  | TB26 - V - Construct-Winter partly * | Ladders & platforms [10 t]; Ladders & platforms [1000 h] | 40,000 | 36,000 | 1000,00 | XN401610 |  | 1000 | 0 | 934 | XNK | 16 | 200 | 200 | C | LND |  | X | N | XN40 | 1610 | N | 16 | X | SS | LND | 1610 | CA16 - critical - CW05 |  |  |  |  |  |  | ChSK | UDF_G4 |  |  |  |  |  |  |  |  |
| XN601610 |  | CA16 Subst&RIE's SK1601 - Install Gratings |  | 30d | 2011-08-10 A | 2011-08-23 A | XN401610 FF, XN721601, XN731601 FS+10d | 100% |  | 2011-09-09 | 2011-10-13 |  |  |  | TB26 - V - Construct-Winter partly * | Grating [225 sqm]; Grating [843.75 h] | 33,750 | 33,750 | 843,75 | XN601610 |  | 843,75 | 0 | 934 | XNK | 16 | 200 | 200 | C | LND |  | X | N | XN60 | 1610 | N | 16 | X | SS | LND | 1610 | CA16 - critical - CW05 |  |  |  |  |  | x | ChSK |  |  |  |  |  |  |  |  |  |
|  | H | **HVAC** |  |  | 2011-04-23 | 2012-06-05 |  |  |  |  |  |  |  |  |  |  |  |  |  |  |  |  |  |  |  |  |  |  |  |  |  |  |  |  |  |  |  |  |  |  |  |  |  |  |  |  |  |  |  |  |  |  |  |  |  |  |  |  |
| XH00161005 |  | CA16 Subst&RIE's - Installation HVAC 1st Floor (first part) |  | 70d | 2011-04-23 A | 2011-07-16 A | XH000000 FF, XN801610 SS+10d, P3H01SA (other project), EH30161005 (other project), P3A00S2 (other project), P3H01D (other project) FS+20d, XH000C00 SS, XC50161010_1 | 100% |  |  |  |  |  |  |  | HVAC - Substation CA16 [942 mhr]; HVAC - Substation CA16 [942 h] |  |  | 9628,00 | XH00161005 |  | 10465 | 942 | 934 |  | 16 | 200 | 200 | C | LND | C2 | X | H | XH00 | 1610 | H | 16 | X | hvac | LND | 1610 | CA16 - critical - CW05 | 2011-02-10 | 2011-04-20 |  |  |  |  | ARMO | UDF_G4 |  | x | 2011-03-17 | 2011-05-23 |  |  |  |  |
| XH00161007 |  | CA16 Subst&RIE's - Installation HVAC 2nd Floor (first part) |  | 55d | 2011-05-13 A | 2011-07-16 A | XH00161005 SS+15d, XH000000 FF, XH001610050 SS+15d | 100% |  |  |  |  |  |  |  | HVAC - Substation CA16 [942 mhr]; HVAC - Substation CA16 [942 h] |  |  | 9628,00 | XH00161007 |  | 10465 | 942 | 934 |  | 16 | 200 | 200 | C | LND | C2 | X | H | XH00 | 1610 | H | 16 | X | hvac | LND | 1610 | CA16 - critical - CW05 | 2011-04-10 | 2011-06-20 |  |  |  |  | ARMO | UDF_G4 |  | x | 2011-04-04 | 2011-06-09 |  |  |  |  |
| XH001610050 |  | CA16 Subst&RIE's - Installation HVAC 1st Floor (second part) |  | 94d | 2011-10-28 | 2012-02-22 | XC50161010_1 |  |  |  |  | 19d | 0d |  |  | HVAC - Substation CA16 [9523 mhr]; HVAC - Substation CA16 [9523 h] |  |  | 9628,00 | XH00161005 |  | 10465 | 942 | 934 |  | 16 | 200 | 200 | C | LND | C2 | X | H | XH00 | 1610 | H | 16 | X | hvac | LND | 1610 | CA16 - critical - CW05 | 2011-02-10 | 2011-04-20 |  |  |  |  | ARMO |  |  | 1 | 2011-03-17 | 2011-05-23 | REL XC50 |  |  |  |
| XH00161007_1 |  | CA16 Subst&RIE's - Installation HVAC 2nd Floor (second part) |  | 80d | 2011-11-03 | 2012-02-11 | XC50161020_1 |  |  |  |  | 55d | 0d |  |  | HVAC - Substation CA16 [9523 mhr]; HVAC - Substation CA16 [9523 h] |  |  | 9628,00 | XH00161007 |  | 10465 | 942 | 934 |  | 16 | 200 | 200 | C | LND | C2 | X | H | XH00 | 1610 | H | 16 | X | hvac | LND | 1610 | CA16 - critical - CW05 | 2011-04-10 | 2011-06-20 |  |  |  |  | ARMO |  |  | 1 | 2011-04-04 | 2011-06-09 | REL XC50 |  |  |  |
| XH00161008 |  | CA16 Subst&RIE's - Installation HVAC 2nd Floor finished | milestone | 0d | 2012-02-11 | 2012-02-11 | XH00161007 FF, XH00161007_1 |  |  |  |  | 77d | 9d |  |  |  |  |  |  | XH00161008 |  | 0 | 0 | 934 |  | 16 | 200 | 200 | C | LND |  | X | H | XH00 | 1610 | H | 16 | X | hvac | LND | 1610 | CA16 - critical - CW05 | 2011-06-20 | 2011-06-20 | CM03 |  |  |  | ARMO |  |  |  | 2011-06-09 | 2011-06-09 |  | P |  |  |
| XH00161006 |  | CA16 Subst&RIE's - Installation HVAC 1st Floor finished | milestone | 0d | 2012-02-22 | 2012-02-22 | XH00161005 FF, XH001610050 |  |  |  |  | 68d | 0d |  |  |  |  |  |  | XH00161006 |  | 0 | 0 | 934 |  | 16 | 200 | 200 | C | LND |  | X | H | XH00 | 1610 | H | 16 | X | hvac | LND | 1610 | CA16 - critical - CW05 | 2011-04-20 | 2011-04-20 | CM02 |  |  |  | ARMO |  |  |  | 2011-05-23 | 2011-05-23 |  | P |  |  |
| XH00161010 |  | CA16 Subst&RIE's -Testing/Commissiong HVAC (Start w. temp. Power) |  | 85d | 2012-02-24 | 2012-06-05 | XH00161006, XH00161008, XH00161005, XH000C10, XH00161007, X0300080, X0300008 FS+20d, X0300060, XH001610050, XH00161007_1 |  |  |  |  | 68d | 0d |  |  |  |  |  |  | XH00161010 |  | 0 | 0 | 934 |  | 16 | 200 | 200 | C | LND | C2 | X | H | XH20 | 1610 | H | 16 | X | hvac | LND | 1610 | CA16 - critical - CW05 | 2011-06-10 | 2011-10-20 |  |  |  |  | ARMO |  |  |  | 2011-07-13 | 2011-10-01 |  |  |  |  |
| XH00161011 |  | CA16 Subst&RIE's - HVAC ready for Heating | milestone | 0d | 2012-03-07 | 2012-03-07 | XH00161010 SS+10d, XR601600 |  |  |  |  | 327.5d | 143.5d |  |  |  |  |  |  | XH00161011 |  | 0 | 0 | 934 |  | 16 | 200 | 200 | C | LND |  | X | H | XH00 | 1610 | H | 16 | X | hvac | LND | 1610 | CA16 - critical - CW05 |  |  | CM02 |  |  |  | ARMO |  |  |  | 2011-07-25 | 2011-07-25 |  |  |  |  |
| XH00161015 |  | CA16 Subst&RIE's -Testing/Commissiong HVAC finished | milestone | 0d | 2012-06-05 | 2012-06-05 | XH00161010 FF |  |  |  |  | 68d | 164d |  |  |  |  |  |  | XH00161015 |  | 0 | 0 | 934 |  | 16 | 200 | 200 | C | LND |  | X | H | XH20 | 1610 | H | 16 | X | hvac | LND | 1610 | CA16 - critical - CW05 | 2011-10-20 | 2011-10-20 | CM04 |  |  |  | ARMO |  |  |  | 2011-10-01 | 2011-10-01 |  | P |  |  |
|  | U | **Package Units** |  |  |  |  |  |  |  |  |  |  |  |  |  |  |  |  |  |  |  |  |  |  |  |  |  |  |  |  |  |  |  |  |  |  |  |  |  |  |  |  |  |  |  |  |  |  |  |  |  |  |  |  |  |  |  |  |
|  | B | **Mechanical - Stationary Equipment** |  |  |  |  |  |  |  |  |  |  |  |  |  |  |  |  |  |  |  |  |  |  |  |  |  |  |  |  |  |  |  |  |  |  |  |  |  |  |  |  |  |  |  |  |  |  |  |  |  |  |  |  |  |  |  |  |
|  | M | **Mechanical - Rotating Equipment** |  |  |  |  |  |  |  |  |  |  |  |  |  |  |  |  |  |  |  |  |  |  |  |  |  |  |  |  |  |  |  |  |  |  |  |  |  |  |  |  |  |  |  |  |  |  |  |  |  |  |  |  |  |  |  |  |
|  | R | **Piping** |  |  | 2011-09-19 | 2011-10-28 |  |  |  |  |  |  |  |  |  |  |  |  |  |  |  |  |  |  |  |  |  |  |  |  |  |  |  |  |  |  |  |  |  |  |  |  |  |  |  |  |  |  |  |  |  |  |  |  |  |  |  |  |
| XR201600 |  | CA16 Subst&RIE's - Piping Prefabrication |  | 15d | 2011-09-19 | 2011-10-05 |  |  |  |  |  | 246d | 0d | as late as possible |  | A/G piping prefabrication [50 Fpi]; A/G Piping (Prefab) [187.5 h] | 550.62 |  | 187,50 | XR201600 |  | 187,5 | 0 | 934 |  | 16 | 200 | 200 | C | LND |  | X | R | XR20 | 1610 | R | 16 | X | PRP | LND | 1610 |  |  |  |  |  |  |  |  |  |  |  |  |  |  |  |  |  |
| XR401600 |  | CA16 Subst&RIE's - Piping Installation |  | 10d | 2011-10-06 | 2011-10-17 | XE411610, XR201600 |  |  |  |  | 199d | 0d | start on or after 2011-10-06 | TB26 - V - Construct-Winter partly * | A/G Piping (Field) [625 h]; A/G piping field installation [100 Fpi] | 1,951.19 |  | 625,00 | XR401600 |  | 625 | 0 | 934 |  | 16 | 200 | 200 | C | LND |  | X | R | XR40 | 1610 | R | 16 | X | PI | LND | 1610 |  | 2011-04-30 | 2011-07-25 | E-06-03-06 |  |  |  |  |  |  |  |  |  |  |  | 2011-07-05 |  |
| XR601600 |  | CA16 Subst&RIE's - Piping Pressure Tests |  | 5d | 2011-10-18 | 2011-10-22 | XR401600 |  |  |  |  | 163d | 0d |  | TB26 - T - Construct-Winter-3 (Dec/Jan/Feb free) * |  |  |  | 51 | XR601600 |  | 0 | 0 | 934 |  | 16 | 200 | 200 | C | LND |  | X | R | XR60 | 1610 | R | 16 | X | HY | LND | 1610 |  | 2011-04-30 | 2011-07-25 | E-06-03-06 |  |  |  |  |  |  |  |  |  |  |  |  |  |
| XR801600 |  | CA16 Subst&RIE's - Piping Reinstatement |  | 5d | 2011-10-24 | 2011-10-28 | XR601600 FF+5d |  |  |  |  | 199d | 295d |  | TB26 - V - Construct-Winter partly * |  |  |  | 26 | XR801600 |  | 0 | 0 | 934 |  | 16 | 200 | 200 | C | LND |  | X | R | XR80 | 1610 | R | 16 | X | PI | LND | 1610 |  | 2011-04-30 | 2011-07-25 | E-06-03-06 |  |  |  |  |  |  |  |  |  |  |  |  | 2011-09-24 |

Notes:
- XN711601: Scope: 09.02.2011: weight: 26 ton - Nov 7 ton; Dec 10 ton; Jan 9 / ton
- XN751601: Scope: 09.02.2011: weight: 53 ton - Nov 29 ton; Dec 24 / ton
- XN301610: Current Status: 19.02.2011 (O.Siegel): CSK hat die Arbeiten wie geplant am / 14-Feb-11 aufgenommen. Die Arbeiten wurden gestoppt aus technischen Grьnden. / Klдrung folgt.
- XN731601: Scope: 09.02.2011: weight: 64 ton - Jan 44 / ton; Feb 20 ton
- XN801610: Current Status: 03.03.2011: Verschiebung Cladding durch Unterbrechung Hauptstahlbau. / Wiederaufnahme der Stahlbauarbeiten 03-Mrz-11
- XN711600: Scope: 09.02.2011: weight: 10 ton - May 10 ton
- XN601610: Current Status: 14.03.2011 (O.Siegel): kein Material auf der Baustelle / vorhanden. Des Weiteren sind die vorhergehende Arbeiten noch nicht so weit / fortgeschritten, dass Grating anfangen kann.
- XH00161005: Current Status: 26.04.2011 (O.Siegel): die Baufreiheit fьr ARMO ist ab der KW 16 gegeben. Die / Prefabrikation hat bereits begonnen. Am 23.04.2011 hat ARMO angefangen die / Gerьste aufzustellen.
- XH001610050: Current Status: 26.04.2011 (O.Siegel): die Baufreiheit fьr ARMO ist ab der KW 16 gegeben. Die / Prefabrikation hat bereits begonnen. Am 23.04.2011 hat ARMO angefangen die / Gerьste aufzustellen.
- XH00161010: Current Status: 21.01.2011 - Siegel - Vorgдnger zur IBN HVAC / Condensat, LP-Dampf, Kьhlwasser von FF + 30 Tage Lag auf FS + 0 geдndert!

| ID | WBS | Activity | Type | Duration | Start | Finish | Predecessors | Complete | Remaining | Planned start | Planned finish | Total float | Free float | Constraint | Calendar | Resources | Cost | Actual cost | TB26 Ressource Budget | UDF_CONTRACT START DATE | UDF_CONTRACT FINISH DATE | UDF_CONTRACT ITEM | UDF_SAVE ACT ID | UDF_BUDGETED LABOR UNIT | UDF_ACTUAL LABOR UNIT | Department | Constr. Area | PMT-Area | PMT-Schedule Org | PMT-Phase | PMT-Respons. | WBS Phase | WBS Discipline | WBS Type of Work | WBS Objects | Russia WBS Discipline (Russia) | Russia Construction Area | Russia WBS Phase | IMS | UPT | Russia WBS Objects | Subcontractor | UDF_Text4 | UDF_CONTRACT INDICATOR | TB26 Semantics | TB26 Material Res Values | UDF_ELECTRICAL START | UDF_ELECTRICAL FINISH | UDF_CONTRACT FINISH DATE REV1 | UDF_CONTRACT START DATE REV1 | UDF_CHECK BASELINE | Zeigen/n. Zeigen | UDF_SELECT UPDATE PROGRESS | UDF_SELECT | Filter | geplanter Start | geplantes Ende | UDF_PENALIZED FINISH | Type of Work | UDF_CONTRACT DATE PENALIZED | UDF_Vendor Representatives |
| --- | --- | --- | --- | --- | --- | --- | --- | --- | --- | --- | --- | --- | --- | --- | --- | --- | --- | --- | --- | --- | --- | --- | --- | --- | --- | --- | --- | --- | --- | --- | --- | --- | --- | --- | --- | --- | --- | --- | --- | --- | --- | --- | --- | --- | --- | --- | --- | --- | --- | --- | --- | --- | --- | --- | --- | --- | --- | --- | --- | --- | --- |
|  | E | **Electrical** |  |  | 2010-07-17 | 2012-08-25 |  |  |  |  |  |  |  |  |  |  |  |  |  |  |  |  |  |  |  |  |  |  |  |  |  |  |  |  |  |  |  |  |  |  |  |  |  |  |  |  |  |  |  |  |  |  |  |  |  |  |  |  |  |  |  |
| IMS-C-000240 |  | CA16 Subst&RIE's - Install EarthingSys_CIVIL |  | 60d | 2010-07-17 A | 2010-09-24 A | EE901610 (other project), XC40161005 FF+10d | 100% |  |  |  |  |  |  |  | Grounding & Lightning [450 pcs]; Grounding & Lightning [5062.5 h] | 202,500 | 202,500 | 5062,50 | 2011-03-10 | 2011-10-10 | E-16-07-06 | IMS-C-000240 | 5062,5 | 5062,5 | 934 | 16 | 200 | 200 | C | LND | X | C | XE91 | 1610 | C | 16 | X | EA | IMS | 1610 | MO11 |  |  |  |  |  |  |  |  |  |  |  |  |  |  |  |  |  |  |  |
| XE411610 |  | CA16 Subst&RIE's - Install Cable Trays |  | 44d | 2011-04-18 A | 2011-05-21 A | P3E16S (other project) FS+2d, XN301610 FS-20d, EE46161010 (other project), EE201610 (other project), EE46510120 (other project) FF, XC521615 FS-12d, XC521610 FF-40d | 100% |  | 2011-04-18 | 2011-06-09 |  |  | start on or after 2011-04-18 |  | Cable trays/conduits [540 m]; Cable trays [1620 h] | 64,800 | 48,000 | 1620,00 | 2011-03-10 | 2011-04-30 | E-15-01-10 | XE411610 | 1620 | 1200 | 934 | 16 | 200 | 200 | C | LND | X | E | XE41 | 1610 | E | 16 | X | EL | LND | 1610 | URMA | CA16 - critical - CW09 | UDF_G4 | m | 1200 | 2011-05-07 | 2011-07-18 | 2011-10-05 | 2011-04-18 | x | C2 |  |  |  |  |  |  |  |  |  |
| XE411615 |  | CA16 Subst&RIE's - Install EarthingSys_E/I |  | 93d | 2011-07-07 A | 2011-12-27 | XN301610, XE411610 FF |  | 49d | 2011-07-07 | 2011-10-22 | -62d | 81.5d | start on or after 2011-07-07 |  |  |  |  | 475 | 2011-03-10 | 2011-10-10 | E-16-07-06 | XE411615 | 0 | 0 | 934 | 16 | 200 | 200 | C | LND | X | E | XE91 | 1610 | E | 16 | X | EA | IMS | 1610 | URMA |  | UDF_G4 |  |  |  |  | 2012-04-05 | 2011-04-18 |  |  | 27.8. |  |  |  |  |  |  |  |  |
| XP341610 |  | CA16 Subst&RIE's - Lighting Panels ordered | milestone | 0d | 2011-09-09 | 2011-09-09 |  |  |  |  |  | -78d | 0d | finish on 2011-09-09 |  |  |  |  | 25 | 2011-05-10 | 2012-01-31 | E-16-03-01 | XP341610 | 0 | 0 | 934 | 16 | 200 | 200 | C | LND | X | E | XE34 | 1610 | E | 17 | X | EL | LND | 1610 | URMA | CA16 - critical - CW09 |  |  |  |  |  | 2012-05-10 | 2011-08-15 | x |  |  |  |  |  |  |  |  |  |  |
| XE341610 |  | CA16 Subst&RIE's - Install Lighting Panels |  | 40d | 2011-11-08 | 2011-12-23 | XP341610 FS+50d, EE46161010 (other project), XE411610 |  |  |  |  | -78d | 114.5d |  |  | Field Panels [27 pcs]; Field panels [540 h] | 21,600 |  | 540,00 | 2011-05-10 | 2012-01-31 | E-16-03-01 | XE341610 | 540 | 0 | 934 | 16 | 200 | 200 | C | LND | X | E | XE34 | 1610 | E | 17 | X | EL | LND | 1610 | URMA | CA16 - critical - CW09 |  |  |  |  |  | 2012-05-10 | 2011-08-15 |  |  | 27.8. |  |  |  |  |  |  |  |  |
| XE701600 |  | CA16 Subst&RIE's - Install Lighting &Small Power |  | 90d | 2011-11-10 | 2012-03-01 | EE761600 (other project), XE411610 FF, XH00161005 SS, EE76510110 (other project) FF+20d, P3E03S2 (other project), P3E09S (other project), E3E0935 (other project), XH001610050 SS, XC50161010 SS+50d |  |  |  |  | 147d | 62.5d |  |  | Cable Pulling [2500 m]; Lighting illuminates [250 pcs]; Lighting (iluminates) [2500 h]; Cable pulling [1250 h] | 150,000 |  | 3750,00 | 2011-05-10 | 2012-01-31 | E-16-03-01 | XE701600 | 3750 | 0 | 934 | 16 | 200 | 200 | C | LND | X | E | XE70 | 1610 | E | 16 | X | EL | LND | 1610 | URMA | CA16 - critical - CW05 |  |  |  |  |  | 2012-05-10 | 2011-08-15 |  |  |  |  |  |  |  |  |  |  |  |
| XE411620 |  | CA16 Subst&RIE's - Install Cable Trays, false floor |  | 30d | 2012-03-05 | 2012-04-10 | XC521615 |  |  |  |  | -212.5d | 0d |  |  |  |  |  | 1620,00 | 2011-03-10 | 2011-04-30 | E-15-01-10 | XE411610 | 1620 | 1200 | 934 | 16 | 200 | 200 | C | LND | X | E | XE41 | 1610 | E | 16 | X | EL | LND | 1610 | URMA | CA16 - critical - CW09 | UDF_G4 | m | 1200 | 2011-05-07 | 2011-07-18 | 2011-10-05 | 2011-04-18 | x | C2 |  |  |  |  |  |  |  |  |  |
| XE60161005 |  | CA16 Subst&RIE's - Cable Termination & Testing / LV Syst. CA16/31 |  | 60d | 2012-03-16 | 2012-05-26 | XE50410015 |  |  |  |  | 76d | 172d |  |  | Cable connecting [680 pcs]; Cable connecting [1700 h] | 68,000 |  | 1700,00 | 2011-04-20 | 2011-11-30 | E-16-02-01 | XE60161005 | 1700 | 0 | 934 | 16 | 200 | 200 | C | LND | X | E | XE60 | 1610 | E | 16 | X | ET | LND | 1610 | URMA | CA16 - critical - CW05 |  |  |  |  |  | 2012-08-14 | 2011-12-10 |  |  |  |  |  |  |  |  |  |  |  |
| XE201610 |  | CA16 Subst&RIE's - Install Trafo's,Swgears,MCC's |  | 70d | 2012-05-04 | 2012-07-27 | XC50161010 SS+25d, IMS-C-000240 FF, XE411615 SS, EE201610 (other project), P3E01BS1 (other project), IMS-C-000240, XE411615 FF, XC520C00, P3E02S1 (other project), XC521615, XE200C00 SS, XE411610 SS+30d, P3S05S (other project) FF+20d, P3E07S1 (other project) FF+20d |  |  |  |  | -212.5d | 0d |  |  | Main Equipment Substations [185 pcs]; Installation main equipment substation [6937.5 h] | 277,500 |  | 6937,50 | 2011-03-10 | 2011-10-10 | E-16-07-06 | XE201610 | 6937,5 | 0 | 934 | 16 | 200 | 200 | C | LND | X | E | XE20 | 1610 | E | 16 | X | SS | LND | 1610 | URMA | CA16 - critical - CW09 |  |  |  |  |  | 2012-04-05 | 2011-04-18 |  | C2 |  | REL XC50 |  |  |  |  |  |  |  |
| XE501610 |  | CA16 Subst&RIE's - Cable Pulling MV Trafos/SGs intern |  | 70d | 2012-05-17 | 2012-08-08 | XE204100 FS-15d, XE405501, XE405101, XE341610 SS+20d, XE500C01, P3E15AS (other project), XE201610 SS+10d, P3E15CS (other project) FF+20d, P3E15BS (other project) FF+20d, XE405401, XE500C00 SS, XE405402, EE561610 (other project) |  |  |  |  | -165.5d | 0d |  | TB26 - V - Construct-Winter partly * | Cable Pulling [17900 m]; Cable pulling [8950 h] | 358,000 |  | 8950,00 | 2011-05-20 | 2012-02-10 | E-16-01-01 | XE501610 | 8950 | 0 | 934 | 16 | 200 | 200 | C | LND | X | E | XE50 | 1610 | E | 16 | X | EL | LND | 1610 | URMA | CA16 - critical - CW09 |  | m | 18500 | 2011-07-19 | 2011-10-07 | 2012-07-01 | 2011-10-01 | x | C2 |  |  |  |  |  |  |  |  |  |
| XE921600 |  | CA16 Subst&RIE's - Install Fire Detection System |  | 75d | 2012-05-17 | 2012-08-14 | XH00161007, XE341610, XC50161010, XJ411610, XH00161005, XE701600, XC50161020, XH001610050, XH00161007_1 |  |  |  |  | 194d | 0d |  |  | Fire Detection System; Fire detection system |  |  | 0,00 |  |  |  | XE921600 | 0 | 0 | 934 | 16 | 200 | 200 | C | UIO | X | E | XE92 | 1610 | E | 16 | X | EL | LND | 1610 |  | CA16 - critical - CW05 |  |  |  |  |  |  |  | x | C6 |  |  | x | 2012-03-04 | 2012-04-23 |  |  |  |  |
| XE961600 |  | CA16 Subst&RIE's - Install Communication System |  | 60d | 2012-05-17 | 2012-07-27 | XC50161010, XH00161005, XE921600 SS, XE701600 FF+30d, P3E13S (other project), XC50161020, XJ411610, XH00161007, E3E1350 (other project), XE341610, XH001610050, XH00161007_1 |  |  |  |  | 209d |  |  |  | Communication System |  |  | 0,00 |  |  |  | XE961600 | 0 | 0 | 934 | 16 | 200 | 200 | C | UIO | X | E | XE96 | 1610 | E | 16 | X | CS | LND | 1610 |  | CA16 - critical - CW05 |  |  |  |  |  |  |  | x |  |  |  | x | 2012-03-04 | 2012-04-23 |  |  |  |  |
| XE50161010 |  | CA16 Subst&RIE's - Install. temp. LV-power generation CA31/16 |  | 25d | 2012-07-27 | 2012-08-25 | XE201610 |  |  |  |  | -107.5d | 0d |  |  |  |  |  |  | 2011-05-20 | 2012-02-10 | E-16-01-01 | XE50161010 | 0 | 0 | 934 | 16 | 200 | 200 | C | LND | X | E | XE50 | 1610 | E | 16 | X | EL | LND | 1610 | URMA | CA16 - critical - CW09 |  |  |  | 2011-10-01 | 2011-10-29 | 2012-07-01 | 2011-10-01 |  |  |  |  |  |  |  |  |  |  |  |
| XE50161005 |  | CA16 Subst&RIE's - Cable Testing Period MV |  | 10d | 2012-08-08 | 2012-08-20 | XE501610 |  |  |  |  | -102.5d | 5d |  |  |  |  |  |  | 2011-05-20 | 2012-02-10 | E-16-01-01 | XE50161005 | 0 | 0 | 934 | 16 | 200 | 200 | C | LND | X | E | XE50 | 1610 | E | 16 | X | EL | LND | 1610 | URMA | CA16 - critical - CW05 |  |  |  | 2011-10-08 | 2011-10-31 | 2012-07-01 | 2011-10-01 | x | C2 |  |  |  |  |  |  |  |  |  |
| XE50161015 |  | CA16 Subst&RIE's - LV power available only for test runs | milestone | 0d | 2012-08-25 | 2012-08-25 | XE50161010, XE50161005 |  |  |  |  | -107.5d | 0d |  |  |  |  |  |  |  | 2012-02-10 | E-16-05-01 | XE50161015 | 0 | 0 | 934 | 16 | 200 | 200 | C | LND | X | E | XE50 | 1610 | E | 16 | X | EL | LND | 1610 | URMA | CA16 - critical - CW09 |  |  |  | 2011-11-30 | 2011-11-30 | 2012-02-10 |  |  | C2 |  |  |  |  |  | 2012-02-10 |  |  |  |
|  | J | **Instrumentation** |  |  | 2012-03-05 | 2012-12-16 |  |  |  |  |  |  |  |  |  |  |  |  |  |  |  |  |  |  |  |  |  |  |  |  |  |  |  |  |  |  |  |  |  |  |  |  |  |  |  |  |  |  |  |  |  |  |  |  |  |  |  |  |  |  |  |
| XJ411610 |  | CA16 Subst&RIE's - Install Secondary Cable Trays |  | 60d | 2012-03-05 | 2012-05-17 | XC521615, EJ141610 (other project), XC521610 FF-40d, EJ461610 (other project), XE411610 FF |  |  |  |  | -73.5d | 0d |  |  | Secondary cable trays [1800 m]; Install secondary cable trays [6750 h] | 270,000 |  | 6750,00 | 2011-03-10 | 2012-04-30 | E-17-04-06 | XJ411610 | 6750 | 0 | 934 | 16 | 200 | 200 | C | LND | X | J | XJ41 | 1610 | J | 16 | X | IN | LND | 1610 | URMA | CA16 - critical - CW05 |  | m | 1500 | 2011-05-07 | 2011-07-18 | 2012-08-01 | 2011-07-30 |  | C2 |  | REL XC50 | x |  |  | 2012-08-01 | J06 |  |  |
| XJ201610 |  | CA16 Subst&RIE's - Install System/ Interface/ Power Distribution Cabinets |  | 45d | 2012-04-10 | 2012-06-04 | XJ200C00 SS, XH00161005 SS+40d, P3U10S3 (other project), XC50161020 SS+25d, IMS-C-000240, XE411615, XJ411610 FS-30d, P3J06CS1 (other project), XC521615, P3J06S1 (other project), P3J05S (other project), P3J06AS (other project), XH001610050 SS+40d |  |  |  |  | -73.5d | 0d |  |  | Junction Boxes/Cabinets/Panels [202 pcs]; Main Equipment Control Building/RIB [6250 mhr]; Install Junction Boxes/ Cabinets/ Panels [5050 h]; Installation Main Equipment Control Building/RIB [6250 h] | 827,000 |  | 11300,00 | 2011-05-01 | 2012-06-20 | E-17-03-01 | XJ201610 | 11300 | 0 | 934 | 16 | 200 | 200 | C | LND | X | J | XJ20 | 1610 | J | 16 | X | SS | LND | 1610 | URMA | CA16 - critical - CW05 |  |  |  |  |  | 2011-12-25 | 2011-10-30 |  | C2 |  | REL XC50 |  |  |  | 2011-12-25 | J06 | x | 009 |
| XJ511610 |  | CA16 Subst&RIE's - Pulling Secondary Cables internal |  | 60d | 2012-05-04 | 2012-07-16 | P3J17S1 (other project) FF, XJ201610 SS+20d, XC521615, XE500C01 |  |  |  |  | -73.5d | 0d |  |  | Singlecore cables [12000 m]; Pull singlecore cables [9000 h] | 360,000 |  | 9000,00 | 2011-03-10 | 2012-04-30 | E-17-04-06 | XJ511610 | 9000 | 0 | 934 | 16 | 200 | 200 | C | LND | X | J | XJ51 | 1610 | J | 16 | X | IN | LND | 1610 | URMA | CA16 - critical - CW05 |  |  | 11757 | 2011-07-13 | 2011-09-20 | 2012-08-01 | 2011-07-30 | x | C2 |  |  |  |  |  | 2012-08-01 | J06 |  |  |
| XJ611610 |  | CA16 Subst&RIE's - Termin Secondary Cables internal |  | 80d | 2012-05-04 | 2012-08-08 | XJ511610 FF+20d, XJ391610 FF |  |  |  |  | -73.5d | 0d |  |  | Termination Control Building [4125 mhr]; Termination Control Building [4125 h] | 412,500 |  | 4125,00 | 2011-03-10 | 2012-04-30 | E-17-04-06 | XJ611610 | 4125 | 0 | 934 | 16 | 200 | 200 | C | LND | X | J | XJ61 | 1610 | J | 16 | X | IN | LND | 1610 | URMA | CA16 - critical - CW05 |  |  |  |  |  | 2012-08-01 | 2011-07-30 | x | C2 |  |  |  |  |  | 2012-08-01 | J06 |  |  |
| XJ52161000 |  | CA16 Subst&RIE's - Ready f. Pull MulticoreCables | milestone | 0d | 2012-05-11 | 2012-05-11 | XJ201610 FS-20d |  |  |  |  | -41.5d | 20d |  |  |  |  |  |  | 2011-03-10 | 2012-04-30 | E-17-04-06 | XJ52161000 | 0 | 0 | 934 | 16 | 200 | 200 | C | LND | X | J | XJ51 | 1610 | J | 16 | X | IN | LND | 1610 | URMA | CA16 - critical - CW05 |  |  |  | 2011-07-13 | 2011-07-13 | 2012-08-01 | 2011-07-30 |  | C2 |  |  |  |  |  | 2012-08-01 | XNK |  |  |
| XJ391610 |  | CA16 Subst&RIE's - Install Earthing Eqpt |  | 18d | 2012-05-25 | 2012-06-16 | XJ201610 FF+10d |  |  |  |  | -56.5d | 40d |  |  |  |  |  |  | 2011-03-10 | 2012-04-30 | E-17-04-06 | XJ391610 | 0 | 0 | 934 | 16 | 200 | 200 | C | LND | X | J | XJ39 | 1610 | J | 16 | X | EA | LND | 1610 | URMA | CA16 - critical - CW05 |  |  |  |  |  | 2012-08-01 | 2011-07-30 |  |  |  |  |  |  |  | 2012-08-01 |  |  |  |
| XJ20161005 |  | CA16 Subst&RIE's - SAT System/ Interface/ Power Distribution Cabinets |  | 15d | 2012-06-04 | 2012-06-22 | XJ52161000, XJ511610 FS-40d, XJ201610, X3J125 FF, XJ304100 |  |  |  |  | -61.5d | 0d |  |  |  |  |  |  |  | 2011-08-30 | E-17-03-02 | XJ20161005 | 0 | 0 | 934 | 16 | 200 | 200 | C | LND | X | J | XJ20 | 1610 | J | 16 | X | LT | IMS | 1610 | URMA | CA16 - critical - CW05 |  |  |  |  |  | 2012-03-01 |  |  | C2 |  |  |  |  |  | 2012-03-01 | J06 |  | 009 |
| XJ20161010 |  | CA16 Subst&RIE's - SAT System/ Interface/ Power Distribution Cabinets finished | milestone | 0d | 2012-06-22 | 2012-06-22 | XJ20161005 FF |  |  |  |  | -61.5d | 35d |  |  |  |  |  |  | 2011-03-10 | 2012-04-30 | E-17-04-06 | XJ20161010 | 0 | 0 | 934 | 16 | 200 | 200 | C | LND | X | J | XJ20 | 1610 | J | 16 | X | LT | LND | 1610 | URMA | CA16 - critical - CW05 |  |  |  |  |  | 2012-08-01 | 2011-07-30 |  |  |  |  |  |  |  | 2012-08-01 | J06 |  | 009 |
| XJ301610 |  | CA16 Subst&RIE's - Install Field Devices |  | 12d | 2012-06-22 | 2012-07-06 | XJ611610 FS-40d, P3J05S (other project) |  |  |  |  | -73.5d | 23d |  |  | Field Instruments [153 pcs]; Install field instruments [841 h] | 33,660 |  | 841,00 | 2011-03-10 | 2012-04-30 | E-17-04-06 | XJ301610 | 841 | 0 | 934 | 16 | 200 | 200 | C | LND | X | J | XJ30 | 1610 | J | 16 | X | IN | LND | 1610 | URMA | CA16 - critical - CW05 |  |  |  |  |  | 2012-08-01 | 2011-07-30 |  |  |  |  |  |  |  | 2012-08-01 |  |  |  |
| XJ801610 |  | CA16 Subst&RIE's - Inspections/ Mech. Acceptance/ Loop Checks |  | 135d | 2012-08-02 | 2012-12-16 | XJ20161005, XJ20161010, XJ301610 FF+40d, IMS-C-000420 FF, YY0100 FF, XE50161015 FS-20d, X030410030 FS-20d, XJ301610, XJ391610, X0300015 FS-20d, XJ611610 SS+15d |  |  |  |  | -112.5d | 0d |  | TB26 - 3 - Construct-winter 7days * | Loop Checks [750 pcs]; Loop checks [3750 h] | 150,000 |  | 3750,00 | 2011-06-10 | 2012-04-30 | E-17-02-01 | XJ801610 | 3750 | 0 | 934 | 16 | 200 | 200 | C | LND | X | J | XJ80 | 1610 | J | 16 | X | LT | LND | 1610 | URMA | CA16 - critical - CW09 |  |  |  |  |  | 2012-08-18 | 2012-03-01 |  | C2 |  |  |  |  |  | 2012-08-18 | J06 |  |  |

Notes:
- XE341610: Current Status: wirdn URMA eingekauft. ein genaues Lieferdatum wird von / UMRA an Linde mitgeteilt.
- XE201610: Current Status: 12.05.2011 (O.Siegel): Installation der Trafos kann erst / starten, wenn Stahlbau fertig ist, die Schienen und das Estrich gelegt worden / sind.
- XE501610: Current Status: im Gebдude befinden sich 8 Trafos
- XE921600: Scope: FDS - 39external sensors / GDS - 17 external sensors / Structured Cable System (SCS) / FOCL / DS + SAME / MDCN
- XE961600: Scope: FDS - 39external sensors / GDS - 17 external sensors / Structured Cable System (SCS) / FOCL / DS + SAME / MDCN
- XJ411610: Current Status: 26.04.2011 (O.Siegel): die Installation der / Instrumentation Cable Trays ist nur in der zweiten Etage! diese werden erst nach / dem Doppelboden montiert.in dem eller befinden sich NUR die elektrische Cable / Trays.
- XJ201610: Scope: System beinhaltet: DCS, SIS, MPS / CMS, SD Cabinets, PU cabinets
- XJ20161005: Current Status: folgendes muss fertiggestellt sein: E-Kabel gelegt und / angeschlossen, CA41 alles fertig (Systeme installiert) und BUS-System / vertiggestellt. / Scope: System beinhaltet: DCS, SIS, MPS / CMS, SD Cabinets, PU cabinets
- XJ20161010: Scope: System beinhaltet: DCS, SIS, MPS / CMS, SD Cabinets, PU cabinets

| ID | WBS | Activity | Type | Duration | Start | Finish | Predecessors | Complete | Remaining | Planned start | Planned finish | Total float | Free float | Constraint | Calendar | Resources | Cost | Actual cost | TB26 Ressource Budget | UDF_CONTRACT FINISH DATE | UDF_CONTRACT ITEM | UDF_SAVE ACT ID | UDF_BUDGETED LABOR UNIT | UDF_ACTUAL LABOR UNIT | Department | Constr. Area | PMT-Area | PMT-Schedule Org | PMT-Phase | PMT-Respons. | WBS Phase | WBS Discipline | WBS Type of Work | WBS Objects | Russia WBS Discipline (Russia) | Russia Construction Area | Russia WBS Phase | IMS | UPT | Inquiry/Order No | Zeigen/n. Zeigen | Russia WBS Objects | Type of Work | UDF_BASELINE DEVELOPMENT | Subcontractor | suspend date | resume date | UDF_Concrete | UDF_CHECK CRITICAL PATH | Check ResLoading | Filter | UDF_CHECK BASELINE | UDF_CONTRACT START DATE | UDF_PLANNED START | UDF_PLANNED FINISH |
| --- | --- | --- | --- | --- | --- | --- | --- | --- | --- | --- | --- | --- | --- | --- | --- | --- | --- | --- | --- | --- | --- | --- | --- | --- | --- | --- | --- | --- | --- | --- | --- | --- | --- | --- | --- | --- | --- | --- | --- | --- | --- | --- | --- | --- | --- | --- | --- | --- | --- | --- | --- | --- | --- | --- | --- |
|  | S | **Safety & Environment** |  |  |  |  |  |  |  |  |  |  |  |  |  |  |  |  |  |  |  |  |  |  |  |  |  |  |  |  |  |  |  |  |  |  |  |  |  |  |  |  |  |  |  |  |  |  |  |  |  |  |  |  |  |
|  | W | **Painting** |  |  |  |  |  |  |  |  |  |  |  |  |  |  |  |  |  |  |  |  |  |  |  |  |  |  |  |  |  |  |  |  |  |  |  |  |  |  |  |  |  |  |  |  |  |  |  |  |  |  |  |  |  |
|  | V | **Insulation** |  |  | 2011-10-18 | 2011-10-27 |  |  |  |  |  |  |  |  |  |  |  |  |  |  |  |  |  |  |  |  |  |  |  |  |  |  |  |  |  |  |  |  |  |  |  |  |  |  |  |  |  |  |  |  |  |  |  |  |  |
| XV501610 |  | CA16 - Insulation Piping |  | 10d | 2011-10-18 | 2011-10-27 | XR401600 |  |  |  |  | 289d | 401.5d |  | TB26 - 3 - Construction Normal 7days * CA17 | Piping insulation [50 sqm]; Piping insulation [375 h] | 7,296.28 |  | 375,00 | 2012-04-30 | E-13-01 | XV501610 | 375 | 0 | 934 | 16 | 200 | 200 | C | LND | X | V | XV50 | 1610 | V | 16 | X | INS | LND |  |  |  |  |  |  |  |  |  |  |  |  |  |  |  |  |
|  | 17 | **CA17 - Extruder Pck. / Additive Handling Line 1+2** |  |  | 2008-09-24 | 2012-12-20 |  |  |  |  |  |  |  |  |  |  |  |  |  |  |  |  |  |  |  |  |  |  |  |  |  |  |  |  |  |  |  |  |  |  |  |  |  |  |  |  |  |  |  |  |  |  |  |  |  |
|  | 00 | **CA17 - General** |  |  | 2008-09-24 | 2012-12-20 |  |  |  |  |  |  |  |  |  |  |  |  |  |  |  |  |  |  |  |  |  |  |  |  |  |  |  |  |  |  |  |  |  |  |  |  |  |  |  |  |  |  |  |  |  |  |  |  |  |
|  | 0B | **General Activities** |  |  | 2012-10-20 | 2012-12-20 |  |  |  |  |  |  |  |  |  |  |  |  |  |  |  |  |  |  |  |  |  |  |  |  |  |  |  |  |  |  |  |  |  |  |  |  |  |  |  |  |  |  |  |  |  |  |  |  |  |
| X0101710 |  | CA17 General - Construction Completion | milestone | 0d | 2012-10-20 | 2012-10-20 | XR401707, XE801708, XE601710, XJ541710, XE911721, XC40174015, XE50176005, XH601300, XE501707, XR401710, XE911719, XE701720, XE701730, XE701740, RF-22301, XJ701760, XE701700, XE701718, XE911731, XR401760, XE50176010, XJ641760, XJ541760, XH00171005, XJ641710, RF-21301, XE911717, XC801736, XC801718, XC801720, XE911709, XE701710, XE911711, XE701736, XE911737, XB10176012, XC191705, XC801730, XR401708, XE911741, XE601760, XJ521707, EX-22401, XE701760, XC801710, EX-21401, XN801760, XB50170320 |  |  |  |  | -111.5d | 0d |  | TB26 - 3 - Construction Normal 7days * CA17 |  |  |  |  |  |  | X0101710 | 0 | 0 | 934 | 17 | 200 | 200 | C | LND | X | 0B | X010 | 1700 | 0 | 17 | X | MC | LND | 2DC8480 | C9-1 | 1700 |  |  |  |  |  |  |  |  |  |  |  |  |  |
| X0051700 |  | CA17 General - Punch Out Works |  | 40d | 2012-11-10 | 2012-12-20 | XV301718, XV501760, XV301710, XJ801720 FF+5d, XJ641730 FF+5d, XV501730, XJ801740 FF+5d, XV501740, XJ641760, XV501710, XE701730, XJ80176005 FF+5d, XE701710, XE801730, XJ641736 FF+5d, XV501736 FF+5d, XJ801760, XE601718, XJ801730 FF+5d, XE701740, XE801718, XJ801736 FF+5d, XJ801710 FF+5d, XE701718, XJ801718 FF+5d, XV501718, XE601730, XE701736, XE601740, XJ641740 FF+5d, XE801710, XE701720, XH00173010, XH00173610, XE701760 |  |  |  |  | -116.5d | 9d |  | TB26 - 3 - Construction Normal 7days * CA17 |  |  |  |  |  |  | X0051700 | 0 | 0 | 934 | 17 | 200 | 200 | C | LND | X | 0B | X010 | 1700 | 0 | 10 | X | MC | LND |  | C9 | 1000 | XNK |  |  |  |  |  |  |  |  |  |  |  |  |
| X0101700 |  | CA17 General - Mechanical Completion | milestone | 0d | 2012-12-15 | 2012-12-15 | XV501707, XC501718, XE911719, XC501730, XE601730, XC501736, XJ801740, XE601760, XC911760, XC501770, XC801718, XE601710, XJ801710, XE601720, XV301730, XH00173610, XE601736, XE601740, XE701740, XV501760, XC801736, XC501710, XV501718, XV501720, XH00173010, XV501736, XE701736, XJ80176005 FF, P3R01S (other project), XC801730, XE911709, XV501708, XH00171008, XH00171010, XE701710, XE911721, XJ801720, XV301720, XE911737, XC911740, XE911741, XE701760, XH601300, XC801720, XV301710, XC911720, XC911736, XJ801760, XJ641760, XE701700, X0101710, XC191707, XC801710, XE911711, XV501710, XH00172010, XV501730, XC40174015, XJ641740, XV301740, XC601700, XC50171005, XH00171015, XH00171810, XE601718, XE701718, XE701720, XE911731, XJ801730, XJ641730, XC481740, XV301760, XE911717, XJ801718, XV301718, XC501720, XE701730, XJ801736, XJ641736, XV301736, XV501740, XB10176015, XC111196095, XB50170320 |  |  |  |  | -111.5d | 14d |  | TB26 - 3 - Construction Normal 7days * CA17 |  |  |  |  |  |  | X0101700 | 0 | 0 | 934 | 17 | 200 | 200 | C | LND | X | 0B | X010 | 1700 | 0 | 17 | X | MC | LND | 2DC8480 | C9-1 | 1700 |  | XC301700 |  |  |  |  |  |  |  |  |  |  |  |
|  | C | **Civil Work** |  |  | 2008-09-24 | 2012-05-26 |  |  |  |  |  |  |  |  |  |  |  |  |  |  |  |  |  |  |  |  |  |  |  |  |  |  |  |  |  |  |  |  |  |  |  |  |  |  |  |  |  |  |  |  |  |  |  |  |  |
| XC111700 |  | CA17 General - Excavation&Surface Prep by U/I/O |  | 294d | 2008-09-24 A | 2009-09-30 A | XC111200 SS | 100% |  |  |  |  |  |  |  |  |  |  |  |  |  | XC111700 | 0 | 0 | 934 | 17 | 200 | 200 | C | UIO | X | C | XC11 | 1700 | C | 17 | X | CW | LND |  |  | 1700 |  |  | MO11 |  |  |  |  |  |  |  |  |  |  |
| XC11170005 |  | CA17 General - Excavation outs.Extr Bldg. |  | 27d | 2010-04-23 A | 2010-05-25 A | XC111710 SS | 100% |  |  |  |  |  |  |  | Excavation [25750 cbm]; Excavation [12875 h] | 1,030,000 | 1,030,000 | 12875,00 |  |  | XC11170005 | 12875 | 12875 | 934 | 17 | 200 | 200 | C | MO02 | X | C | XC11 | 1700 | C | 10 | X | P | LND | 999 |  | 1010 |  |  | MO11 |  |  |  |  |  |  |  |  |  |  |
| XC11170010 |  | CA17 General - SubBase (Gravel/Geogrid) for Concrete |  | 12d | 2010-05-24 A | 2010-06-07 A | XC11170005 FS-2d | 100% |  | 2010-05-24 | 2010-06-05 |  |  |  |  | Sub Base for Concrete/Paving&Roads (Gravel) [15000 cbm]; Subbase for Concrete [15000 h] | 1,500,000 | 500,000 | 15000,00 |  |  | XC11170010 | 15000 | 15000 | 934 | 17 | 200 | 200 | C | MO02 | X | C | XC11 | 1700 | C | 10 | X | P | LND | 999 |  | 1010 |  |  | MO11 |  |  |  |  |  |  |  |  |  |  |
| XC151700 |  | CA17 General - Piling outs.Extr Bldg. |  | 2d | 2010-09-14 A | 2010-09-15 A | XC151710 FS+7d, XC11170005, EC151708 (other project) FS+8d, XC111700, XC11170010 SS+5d, F2910, EC151707 (other project) FS+8d | 100% |  |  |  |  |  |  |  | Piles driven [65 pcs]; Piles driven [487.5 h] | 19,500 | 19,500 | 487,50 |  |  | XC151700 | 487,5 | 487,5 | 934 | 17 | 200 | 200 | C | MO02 | X | C | XC15 | 1700 | C | 17 | X | P | LND |  |  | 1700 |  |  | MO11 |  |  |  |  |  |  |  |  |  |  |
| XC191700 |  | CA17 General - Backfill outside Extruder Bldg |  | 484d | 2010-09-18 A | 2012-03-30 | XC20171005 FS+5d, XC191707 FF+20d | 100% | 0d | 2010-09-18 | 2012-11-12 | 36d | 6d |  | TB26 - T - Construct-Winter-3 (Dec/Jan/Feb free) * | Backfill & Compaction [6000 cbm]; Backfill & Compaction [9000 h] | 540,000 | 302,755.51 | 9000,00 |  |  | XC191700 | 9000 | 9000 | 934 | 17 | 200 | 200 | C | CiC | X | C | XC19 | 1700 | C | 17 | X | mis | LND |  |  | 1700 |  |  | MO11 | 2010-11-01 | 2010-11-30 |  |  |  |  |  |  |  |  |
| XC15170010 |  | CA17 General - Piling outs.Extr Bldg. (below entrance hall) |  | 6d | 2010-11-06 A | 2010-11-12 A | EC151708 (other project) FS+8d, XC151700 FS+7d, XC11170005, XC111700, EC151707 (other project) FS+8d, XC11170010 SS+5d, F2910 | 100% |  |  |  |  |  |  |  |  |  |  | 65 |  |  | XC15170010 | 0 | 0 | 934 | 17 | 200 | 200 | C | MO02 | X | C | XC15 | 1700 | C | 17 | X | P | LND |  |  | 1700 |  |  | MO11 |  |  |  |  |  |  |  |  |  |  |
| XC301700 |  | CA17 General - UG Install in-/ outside Extruder Bldg (incl. Precast Manholes) |  | 30d | 2011-10-04 | 2011-11-02 | P3S08BS (other project) FF+30d, XC201707, P3R02S1 (other project), P3R02BS (other project), P3S08S (other project) FF+30d, ER441700 (other project), XC310C00, XC20171005 FS+20d, XC300C00 FS+25d, P3C02D4 (other project) FS+30d, P3R02AS1 (other project), XC300C00 SS, EC301700 (other project), XC191700 FF-75d |  |  |  |  | -3d | 63d |  | TB26 - 3 - Construction Normal 7days * CA17 | Cast Iron U/G Piping [860 m]; Concrete Manholes [30 pcs]; Floor Drains / Catch Basins [4 pcs]; Fire water hydrants/monitors [3 pcs]; FRP U/G Piping [675 m]; Cast iron U/G piping [17200 h]; concrete manholes [8250 h]; floor drains / catch basins [100 h]; fire water hydrants/ monitors [218 h]; FRP U/G piping [8437 h] | 685,407.89 |  | 68412,50 |  |  | XC301700 | 34205 | 0 | 934 | 17 | 200 | 200 | C | CiC | X | C | XC30 | 1700 | C | 17 | X | mis | LND |  |  | 1700 |  | XC301700 |  |  |  | 1 | XC301700 | UG |  |  |  |  |  |
| XC191705 |  | CA17 General - Backfill outside Extruder Bldg |  | 30d | 2012-03-01 | 2012-04-11 | XC40171013, XC301700 FF+10d |  |  |  |  | 66d | 0d |  | TB26 - T - Construct-Winter-3 (Dec/Jan/Feb free) * | Backfill & Compaction [5800 cbm]; Backfill & Compaction [8700 h] | 522,000 |  | 17400,00 |  |  | XC191705 | 8700 | 0 | 934 | 17 | 200 | 200 | C | CiC | X | C | XC19 | 1700 | C | 17 | X | mis | LND |  |  | 1700 |  | XC301700 | MO11 | 2010-11-01 | 2010-11-30 |  |  | X | 1 | x |  |  |  |
| XC111196075 |  | CA17 General - Backfill outside Extruder Bldg |  | 30d | 2012-03-02 | 2012-04-12 | XC111196085 FF+10d |  |  |  |  | 76d | 0d |  | TB26 - T - Construct-Winter-3 (Dec/Jan/Feb free) * | Backfill & Compaction [5800 cbm]; Backfill & Compaction [8700 h] | 522,000 |  | 17400,00 |  |  | XC191705 | 8700 | 0 | 934 | 17 | 200 | 200 | C | CiC | X | C | XC19 | 1700 | C | 17 | X | mis | LND |  |  | 1700 |  | XC301700 | MO11 | 2010-11-01 | 2010-11-30 |  |  | X | 1 | x |  |  |  |
| XC111196085 |  | CA17 General - UG Install outside Extruder Bldg (incl. Precast Manholes) |  | 30d | 2012-03-03 | 2012-04-02 |  |  |  |  |  | 89d | 0d | start on or after 2012-03-03 | TB26 - 3 - Construction Normal 7days * CA17 | Cast Iron U/G Piping [860 m]; Concrete Manholes [30 pcs]; Floor Drains / Catch Basins [4 pcs]; Fire water hydrants/monitors [4 pcs]; FRP U/G Piping [675 m]; Cast iron U/G piping [17200 h]; concrete manholes [8250 h]; floor drains / catch basins [100 h]; fire water hydrants/ monitors [219.5 h]; FRP U/G piping [8438 h] | 687,907.89 |  | 68412,50 |  |  | XC301700 | 34207,5 | 0 | 934 | 17 | 200 | 200 | C | CiC | X | C | XC30 | 1700 | C | 17 | X | mis | LND |  |  | 1700 |  | XC301700 |  |  |  | 1 | XC301700 | UG |  |  |  |  |  |
| XC601700 |  | CA17 General - Paving outside Extruder Building |  | 30d | 2012-04-24 | 2012-05-25 | EC601700 (other project), IMS-C-000120 FF, XC191705 SS+40d, XC191700 FF+40d, XC191705 FF+25d, XC191700 SS+25d |  |  |  |  | 90d | 201.5d |  | TB26 - 3 - Construction Normal 7days * CA17 | Concrete paved areas & concrete Roads [700 sqm]; Open ditches; Gravel [600 sqm]; Concrete paved areas & concrete roads [2625 h]; open ditches; Gravel [30 h] | 8,960.42 |  | 5310,00 |  |  | XC601700 | 2655 | 0 | 934 | 17 | 200 | 200 | C | CiC | X | C | XC60 | 1700 | C | 17 | X | PV | LND |  |  | 1700 |  | XC301700 | MO11 |  |  | 1 |  |  |  |  |  |  |  |
| XC111196095 |  | CA17 General - Paving outside Extruder Building |  | 30d | 2012-04-25 | 2012-05-26 | XC111196075 SS+40d, XC111196075 FF+25d |  |  |  |  | 89d | 200.5d |  | TB26 - 3 - Construction Normal 7days * CA17 | Concrete paved areas & concrete Roads [700 sqm]; Open ditches; Gravel [600 sqm]; Concrete paved areas & concrete roads [2625 h]; open ditches; Gravel [30 h] | 8,960.42 |  | 5310,00 |  |  | XC601700 | 2655 | 0 | 934 | 17 | 200 | 200 | C | CiC | X | C | XC60 | 1700 | C | 17 | X | PV | LND |  |  | 1700 |  | XC301700 | MO11 |  |  | 1 |  |  |  |  |  |  |  |
|  | R | **Piping** |  |  | 2011-10-18 | 2012-02-28 |  |  |  |  |  |  |  |  |  |  |  |  |  |  |  |  |  |  |  |  |  |  |  |  |  |  |  |  |  |  |  |  |  |  |  |  |  |  |  |  |  |  |  |  |  |  |  |  |  |
| XR201700 |  | CA17 General - Piping Prefabrication (Deluge) |  | 70d | 2011-10-18 | 2011-12-27 | XR500C00 FS+15d |  |  |  |  | 19d | 0d | as late as possible | TB26 - 3 - Construction Normal 7days * CA17 |  |  |  | 1960 |  |  | XR201700 | 0 | 0 | 934 | 17 | 200 | 200 | C | LND | X | R | XR20 | 1700 | R | 17 | X | PRP | LND |  |  | 1700 |  |  |  |  |  |  |  |  |  |  |  |  |  |
| XR401700 |  | CA17 General - Piping Installation (Deluge) |  | 70d | 2011-11-18 | 2012-02-02 | XR201700 SS+30d, XR401710 SS |  |  |  |  | 19d | 0d | start on or after 2011-08-03 | TB26 - 3 - Construction Normal 7days * CA17 | Deluge Piping [9200 Fpi]; Deluge piping [57500 h] | 2,300,000 |  | 57500,00 |  | E-06-03-07 | XR401700 | 57500 | 0 | 934 | 17 | 200 | 200 | C | LND | X | R | XR40 | 1700 | R | 17 | X | PI | LND |  |  | 1700 |  |  |  |  |  |  |  |  |  |  | 2011-02-25 | 2011-05-12 |  |
| XR601700 |  | CA17 General - Piping Pressure Tests (Deluge) |  | 25d | 2012-01-19 | 2012-02-12 | XR401700 FF+10d |  |  |  |  | 19d | 0d |  | TB26 - 3 - Construction Normal 7days * CA17 |  |  |  | 435 |  | E-06-03-07 | XR601700 | 0 | 0 | 934 | 17 | 200 | 200 | C | LND | X | R | XR60 | 1700 | R | 17 | X | HY | LND |  |  | 1700 |  |  |  |  |  |  |  |  |  |  |  |  |  |
| XR801700 |  | CA17 General - Piping Reinstatement (Deluge) |  | 15d | 2012-02-13 | 2012-02-28 | XR601700 |  |  |  |  | 112d | 0d |  | TB26 - 3 - Construction Normal 7days * CA17 |  |  |  | 218 | 2012-02-25 | E-06-03-07 | XR801700 | 0 | 0 | 934 | 17 | 200 | 200 | C | LND | X | R | XR80 | 1700 | R | 17 | X | PI | LND |  |  | 1700 |  |  |  |  |  |  | XR801707 |  |  |  |  |  | 2012-05-11 |

Notes:
- X0051700: Current Status: 110711 WL: Pred FF+5d instead of FS
- XC111700: P3 Activity Log Info: incl. Dewatering/Drainage
- XC301700: P3 Activity Log Info: Clarification Prefab / Catch Basins/pulling pits
- XC111196085: P3 Activity Log Info: Clarification Prefab / Catch Basins/pulling pits

| ID | WBS | Activity | Type | Duration | Start | Finish | Predecessors | Complete | Planned start | Planned finish | Total float | Free float | Constraint | Calendar | Resources | Cost | Filter | TB26 Ressource Budget | UDF_CONTRACT START DATE | UDF_CONTRACT FINISH DATE | UDF_CONTRACT ITEM | UDF_CONTRACT FINISH DATE REV1 | UDF_CONTRACT START DATE REV1 | UDF_SAVE ACT ID | UDF_BUDGETED LABOR UNIT | UDF_ACTUAL LABOR UNIT | UDF_INDICATOR | Department | Constr. Area | PMT-Area | PMT-Schedule Org | PMT-Phase | PMT-Respons. | WBS Phase | WBS Discipline | WBS Type of Work | WBS Objects | Russia WBS Discipline (Russia) | Russia Construction Area | Russia WBS Phase | IMS | UPT | Russia WBS Objects | Subcontractor | geplanter Start | geplantes Ende | UDF_CHECK BASELINE | Type of Work | Zeigen/n. Zeigen | UDF_SELECT UPDATE PROGRESS | TB26 Semantics | Inquiry/Order No | UDF_Concrete | UDF_SELECT |
| --- | --- | --- | --- | --- | --- | --- | --- | --- | --- | --- | --- | --- | --- | --- | --- | --- | --- | --- | --- | --- | --- | --- | --- | --- | --- | --- | --- | --- | --- | --- | --- | --- | --- | --- | --- | --- | --- | --- | --- | --- | --- | --- | --- | --- | --- | --- | --- | --- | --- | --- | --- | --- | --- | --- |
|  | E | **Electrical** |  |  | 2012-03-02 | 2012-11-12 |  |  |  |  |  |  |  |  |  |  |  |  |  |  |  |  |  |  |  |  |  |  |  |  |  |  |  |  |  |  |  |  |  |  |  |  |  |  |  |  |  |  |  |  |  |  |  |  |
| XE701700 |  | CA17 General - Install Lighting & Small Power |  | 170d | 2012-03-02 | 2012-08-22 | EE761700 (other project), XC20171010, EE76510110 (other project), P3E03S2 (other project), XP341610 FS+40d, EE76170010 (other project), XE401710 FS-15d |  |  |  | -53d | 0d |  | TB26 - 3 - Construction Normal 7days * CA17 | Cable Pulling [9900 m]; Cable pulling [4950 h] | 198,000 | x | 4950,00 | 2011-05-10 | 2012-01-31 | E-16-03-01 | 2012-05-10 | 2011-08-15 | XE701700 | 4950 | 0 | UDF_G2 | 934 | 17 | 200 | 200 | C | LND | X | E | XE70 | 1700 | E | 17 | X | EL | LND | 1700 | URMA |  |  |  |  |  |  |  |  |  |  |
| XE921700 |  | CA17 General - Install Fire Detection System |  | 80.12d | 2012-08-23 | 2012-11-12 | XE701700 |  |  |  | 139.38d |  |  | TB26 - 3 - Construction Normal 7days * CA17 | Fire Detection System; Fire detection system |  | x | 0,00 |  |  |  |  |  | XE921700 | 0 | 0 |  | 934 | 17 | 200 | 200 | C | UIO | X | E | XE92 | 1700 | E | 17 | X | FGDS | LND | 1700 |  | 2012-01-19 | 2012-08-13 | x |  |  |  |  |  |  |  |
| XE961700 |  | CA17 General - Install Communication System |  | 80d | 2012-08-23 | 2012-11-11 | XE701700 |  |  |  | 139.5d |  |  | TB26 - 3 - Construction Normal 7days * CA17 | Communication System |  | x | 0,00 |  |  |  |  |  | XE961700 | 0 | 0 |  | 934 | 17 | 200 | 200 | C | LND | X | E | XE96 | 1700 | E | 17 | X | CS | LND | 1700 |  | 2012-01-19 | 2012-08-13 | x |  |  |  |  |  |  |  |
|  | J | **Instrumentation** |  |  |  |  |  |  |  |  |  |  |  |  |  |  |  |  |  |  |  |  |  |  |  |  |  |  |  |  |  |  |  |  |  |  |  |  |  |  |  |  |  |  |  |  |  |  |  |  |  |  |  |  |
|  | 01 | **CA17 - Auxiliary/Monorail/Crane Structures** |  |  |  |  |  |  |  |  |  |  |  |  |  |  |  |  |  |  |  |  |  |  |  |  |  |  |  |  |  |  |  |  |  |  |  |  |  |  |  |  |  |  |  |  |  |  |  |  |  |  |  |  |
|  | 04 | **CA17 - Internal Pipe Racks** |  |  | 2011-03-31 | 2012-01-10 |  |  |  |  |  |  |  |  |  |  |  |  |  |  |  |  |  |  |  |  |  |  |  |  |  |  |  |  |  |  |  |  |  |  |  |  |  |  |  |  |  |  |  |  |  |  |  |  |
|  | C | **Civil Work** |  |  |  |  |  |  |  |  |  |  |  |  |  |  |  |  |  |  |  |  |  |  |  |  |  |  |  |  |  |  |  |  |  |  |  |  |  |  |  |  |  |  |  |  |  |  |  |  |  |  |  |  |
|  | N | **Structural Steel** |  |  | 2011-03-31 | 2012-01-10 |  |  |  |  |  |  |  |  |  |  |  |  |  |  |  |  |  |  |  |  |  |  |  |  |  |  |  |  |  |  |  |  |  |  |  |  |  |  |  |  |  |  |  |  |  |  |  |  |
| XN701704 |  | CA17 SK1704 - KMD Assy Drawings | milestone | 0d | 2011-03-31 A | 2011-03-31 A |  | 100% |  |  |  |  | finish on 2011-03-31 | TB26 - 3 - Construction Normal 7days * CA17 |  |  |  | 22t |  |  |  |  |  | XN701704 | 0 | 0 |  | 934 | 17 | 200 | 200 | C | LND | X | N | XN05 | 1704 | N | 17 | X | SS | LND | 1704 |  |  |  | x | XNK | KMD |  |  |  |  |  |
| XN711704 |  | CA17 SK1704 - Steel Deliveries | milestone | 0d | 2011-04-12 A | 2011-04-12 A |  | 100% |  |  |  |  | finish on 2011-04-11 | TB26 - 3 - Construction Normal 7days * CA17 |  |  |  | 22t |  |  |  |  |  | XN711704 | 0 | 0 |  | 934 | 17 | 200 | 200 | C | LND | X | N | XN06 | 1704 | N | 17 | X | SS | LND | 1704 |  |  |  | x | XNK | SD |  |  |  |  |  |
| XN701706 |  | CA17 SK1706 - KMD Assy Drawings | milestone | 0d | 2011-05-01 A | 2011-05-01 A |  | 100% |  |  |  |  | finish on 2011-04-29 | TB26 - 3 - Construction Normal 7days * CA17 |  |  |  | 22t |  |  |  |  |  | XN701706 | 0 | 0 |  | 934 | 17 | 200 | 200 | C | LND | X | N | XN05 | 1700 | N | 17 | X | SS | LND | 1700 |  |  |  | x | XNK | KMD |  |  |  |  |  |
| XN701709 |  | CA17 SK1705 - KMD Assy Drawings | milestone | 0d | 2011-05-01 A | 2011-05-01 A |  | 100% |  |  |  |  | finish on 2011-04-29 | TB26 - 3 - Construction Normal 7days * CA17 |  |  |  | 22t |  |  |  |  |  | XN701709 | 0 | 0 |  | 934 | 17 | 200 | 200 | C | LND | X | N | XN05 | 1700 | N | 17 | X | SS | LND | 1700 |  |  |  | x | XNK | KMD |  |  |  |  |  |
| XN701705 |  | CA17 SK1705 - KMD Assy Drawings | milestone | 0d | 2011-05-06 A | 2011-05-06 A |  | 100% |  |  |  |  | finish on 2011-05-06 | TB26 - 3 - Construction Normal 7days * CA17 |  |  |  | 22t |  |  |  |  |  | XN701705 | 0 | 0 |  | 934 | 17 | 200 | 200 | C | LND | X | N | XN05 | 1700 | N | 17 | X | SS | LND | 1700 |  |  |  | x | XNK | KMD |  |  |  |  |  |
| XN701700 |  | CA17 General - KMD Assy Drawings | milestone | 0d | 2011-05-19 A | 2011-05-19 A |  | 100% |  |  |  |  | finish on 2011-05-19 | TB26 - 3 - Construction Normal 7days * CA17 |  |  |  | 22t |  |  |  |  |  | XN701700 | 0 | 0 |  | 934 | 17 | 200 | 200 | C | LND | X | N | XN05 | 1700 | N | 17 | X | SS | LND | 1700 |  |  |  | x | XNK | KMD |  |  |  |  |  |
| XN711705 |  | CA17 SK1705 - Steel Deliveries | milestone | 0d | 2011-08-16 A | 2011-08-16 A |  | 100% |  |  |  |  | finish on 2011-08-15 | TB26 - 3 - Construction Normal 7days * CA17 |  |  |  | 22t |  |  |  |  |  | XN711705 | 0 | 0 |  | 934 | 17 | 200 | 200 | C | LND | X | N | XN06 | 1700 | N | 17 | X | SS | LND | 1700 |  |  |  |  | XNK | SD | 27.8. |  |  |  |  |
| XN711706 |  | CA17 SK1706 - Steel Deliveries | milestone | 0d | 2011-08-16 A | 2011-08-16 A |  | 100% |  |  |  |  | finish on 2011-08-15 | TB26 - 3 - Construction Normal 7days * CA17 |  |  |  | 22t |  |  |  |  |  | XN711706 | 0 | 0 |  | 934 | 17 | 200 | 200 | C | LND | X | N | XN06 | 1700 | N | 17 | X | SS | LND | 1700 |  |  |  |  | XNK | SD | 27.8. |  |  |  |  |
| XN711709 |  | CA17 SK1709 - Steel Deliveries | milestone | 0d | 2011-08-16 A | 2011-08-16 A |  | 100% |  |  |  |  | finish on 2011-08-15 | TB26 - 3 - Construction Normal 7days * CA17 |  |  |  | 22t |  |  |  |  |  | XN711709 | 0 | 0 |  | 934 | 17 | 200 | 200 | C | LND | X | N | XN06 | 1700 | N | 17 | X | SS | LND | 1700 |  |  |  |  | XNK | SD | 27.8. |  |  |  |  |
| XN201704 |  | CA17 SK1704 - Installation Steel Struc Piperack |  | 40d | 2011-11-25 | 2012-01-10 | XN711704 FS+10d, XN201710, P3N02UN (other project), XC20171015 SS+10d, XN701704 |  |  |  | -27d | 0d |  | TB26 - 3 - Construction Normal 7days * CA17 | Piperacks, Main Structures [130 t]; Piperacks, Main structures [5525 h] | 8,129.97 |  | 5525,00 | 2011-04-20 | 2011-05-20 | E-04-10 |  |  | XN201704 | 5525 | 0 |  | 934 | 17 | 200 | 200 | C | LND | X | N | XN20 | 1704 | N | 17 | X | SS | LND | 1704 | ChSK |  |  |  | PU10 |  |  | t | 2DC8990 |  |  |
|  | H | **HVAC** |  |  |  |  |  |  |  |  |  |  |  |  |  |  |  |  |  |  |  |  |  |  |  |  |  |  |  |  |  |  |  |  |  |  |  |  |  |  |  |  |  |  |  |  |  |  |  |  |  |  |  |  |
|  | U | **Package Units** |  |  |  |  |  |  |  |  |  |  |  |  |  |  |  |  |  |  |  |  |  |  |  |  |  |  |  |  |  |  |  |  |  |  |  |  |  |  |  |  |  |  |  |  |  |  |  |  |  |  |  |  |
|  | B | **Mechanical - Stationary Equipment** |  |  |  |  |  |  |  |  |  |  |  |  |  |  |  |  |  |  |  |  |  |  |  |  |  |  |  |  |  |  |  |  |  |  |  |  |  |  |  |  |  |  |  |  |  |  |  |  |  |  |  |  |
|  | M | **Mechanical - Rotating Equipment** |  |  |  |  |  |  |  |  |  |  |  |  |  |  |  |  |  |  |  |  |  |  |  |  |  |  |  |  |  |  |  |  |  |  |  |  |  |  |  |  |  |  |  |  |  |  |  |  |  |  |  |  |
|  | R | **Piping** |  |  |  |  |  |  |  |  |  |  |  |  |  |  |  |  |  |  |  |  |  |  |  |  |  |  |  |  |  |  |  |  |  |  |  |  |  |  |  |  |  |  |  |  |  |  |  |  |  |  |  |  |
|  | E | **Electrical** |  |  |  |  |  |  |  |  |  |  |  |  |  |  |  |  |  |  |  |  |  |  |  |  |  |  |  |  |  |  |  |  |  |  |  |  |  |  |  |  |  |  |  |  |  |  |  |  |  |  |  |  |
|  | J | **Instrumentation** |  |  |  |  |  |  |  |  |  |  |  |  |  |  |  |  |  |  |  |  |  |  |  |  |  |  |  |  |  |  |  |  |  |  |  |  |  |  |  |  |  |  |  |  |  |  |  |  |  |  |  |  |
|  | S | **Safety & Environment** |  |  |  |  |  |  |  |  |  |  |  |  |  |  |  |  |  |  |  |  |  |  |  |  |  |  |  |  |  |  |  |  |  |  |  |  |  |  |  |  |  |  |  |  |  |  |  |  |  |  |  |  |
|  | W | **Painting** |  |  |  |  |  |  |  |  |  |  |  |  |  |  |  |  |  |  |  |  |  |  |  |  |  |  |  |  |  |  |  |  |  |  |  |  |  |  |  |  |  |  |  |  |  |  |  |  |  |  |  |  |
|  | V | **Insulation** |  |  |  |  |  |  |  |  |  |  |  |  |  |  |  |  |  |  |  |  |  |  |  |  |  |  |  |  |  |  |  |  |  |  |  |  |  |  |  |  |  |  |  |  |  |  |  |  |  |  |  |  |
|  | 05 | **CA17 - Internal Platforms & Frames** |  |  |  |  |  |  |  |  |  |  |  |  |  |  |  |  |  |  |  |  |  |  |  |  |  |  |  |  |  |  |  |  |  |  |  |  |  |  |  |  |  |  |  |  |  |  |  |  |  |  |  |  |
|  | C | **Civil Work** |  |  |  |  |  |  |  |  |  |  |  |  |  |  |  |  |  |  |  |  |  |  |  |  |  |  |  |  |  |  |  |  |  |  |  |  |  |  |  |  |  |  |  |  |  |  |  |  |  |  |  |  |
|  | N | **Structural Steel** |  |  |  |  |  |  |  |  |  |  |  |  |  |  |  |  |  |  |  |  |  |  |  |  |  |  |  |  |  |  |  |  |  |  |  |  |  |  |  |  |  |  |  |  |  |  |  |  |  |  |  |  |
|  | H | **HVAC** |  |  |  |  |  |  |  |  |  |  |  |  |  |  |  |  |  |  |  |  |  |  |  |  |  |  |  |  |  |  |  |  |  |  |  |  |  |  |  |  |  |  |  |  |  |  |  |  |  |  |  |  |
|  | U | **Package Units** |  |  |  |  |  |  |  |  |  |  |  |  |  |  |  |  |  |  |  |  |  |  |  |  |  |  |  |  |  |  |  |  |  |  |  |  |  |  |  |  |  |  |  |  |  |  |  |  |  |  |  |  |
|  | B | **Mechanical - Stationary Equipment** |  |  |  |  |  |  |  |  |  |  |  |  |  |  |  |  |  |  |  |  |  |  |  |  |  |  |  |  |  |  |  |  |  |  |  |  |  |  |  |  |  |  |  |  |  |  |  |  |  |  |  |  |
|  | M | **Mechanical - Rotating Equipment** |  |  |  |  |  |  |  |  |  |  |  |  |  |  |  |  |  |  |  |  |  |  |  |  |  |  |  |  |  |  |  |  |  |  |  |  |  |  |  |  |  |  |  |  |  |  |  |  |  |  |  |  |
|  | R | **Piping** |  |  |  |  |  |  |  |  |  |  |  |  |  |  |  |  |  |  |  |  |  |  |  |  |  |  |  |  |  |  |  |  |  |  |  |  |  |  |  |  |  |  |  |  |  |  |  |  |  |  |  |  |
|  | E | **Electrical** |  |  |  |  |  |  |  |  |  |  |  |  |  |  |  |  |  |  |  |  |  |  |  |  |  |  |  |  |  |  |  |  |  |  |  |  |  |  |  |  |  |  |  |  |  |  |  |  |  |  |  |  |
|  | J | **Instrumentation** |  |  |  |  |  |  |  |  |  |  |  |  |  |  |  |  |  |  |  |  |  |  |  |  |  |  |  |  |  |  |  |  |  |  |  |  |  |  |  |  |  |  |  |  |  |  |  |  |  |  |  |  |
|  | S | **Safety & Environment** |  |  |  |  |  |  |  |  |  |  |  |  |  |  |  |  |  |  |  |  |  |  |  |  |  |  |  |  |  |  |  |  |  |  |  |  |  |  |  |  |  |  |  |  |  |  |  |  |  |  |  |  |
|  | W | **Painting** |  |  |  |  |  |  |  |  |  |  |  |  |  |  |  |  |  |  |  |  |  |  |  |  |  |  |  |  |  |  |  |  |  |  |  |  |  |  |  |  |  |  |  |  |  |  |  |  |  |  |  |  |
|  | V | **Insulation** |  |  |  |  |  |  |  |  |  |  |  |  |  |  |  |  |  |  |  |  |  |  |  |  |  |  |  |  |  |  |  |  |  |  |  |  |  |  |  |  |  |  |  |  |  |  |  |  |  |  |  |  |
|  | 06 | **CA17 - Cladding Support Structure & Cladding** |  |  |  |  |  |  |  |  |  |  |  |  |  |  |  |  |  |  |  |  |  |  |  |  |  |  |  |  |  |  |  |  |  |  |  |  |  |  |  |  |  |  |  |  |  |  |  |  |  |  |  |  |
|  | C | **Civil Work** |  |  |  |  |  |  |  |  |  |  |  |  |  |  |  |  |  |  |  |  |  |  |  |  |  |  |  |  |  |  |  |  |  |  |  |  |  |  |  |  |  |  |  |  |  |  |  |  |  |  |  |  |
|  | N | **Structural Steel** |  |  |  |  |  |  |  |  |  |  |  |  |  |  |  |  |  |  |  |  |  |  |  |  |  |  |  |  |  |  |  |  |  |  |  |  |  |  |  |  |  |  |  |  |  |  |  |  |  |  |  |  |
|  | H | **HVAC** |  |  |  |  |  |  |  |  |  |  |  |  |  |  |  |  |  |  |  |  |  |  |  |  |  |  |  |  |  |  |  |  |  |  |  |  |  |  |  |  |  |  |  |  |  |  |  |  |  |  |  |  |
|  | U | **Package Units** |  |  |  |  |  |  |  |  |  |  |  |  |  |  |  |  |  |  |  |  |  |  |  |  |  |  |  |  |  |  |  |  |  |  |  |  |  |  |  |  |  |  |  |  |  |  |  |  |  |  |  |  |
|  | B | **Mechanical - Stationary Equipment** |  |  |  |  |  |  |  |  |  |  |  |  |  |  |  |  |  |  |  |  |  |  |  |  |  |  |  |  |  |  |  |  |  |  |  |  |  |  |  |  |  |  |  |  |  |  |  |  |  |  |  |  |
|  | M | **Mechanical - Rotating Equipment** |  |  |  |  |  |  |  |  |  |  |  |  |  |  |  |  |  |  |  |  |  |  |  |  |  |  |  |  |  |  |  |  |  |  |  |  |  |  |  |  |  |  |  |  |  |  |  |  |  |  |  |  |
|  | R | **Piping** |  |  |  |  |  |  |  |  |  |  |  |  |  |  |  |  |  |  |  |  |  |  |  |  |  |  |  |  |  |  |  |  |  |  |  |  |  |  |  |  |  |  |  |  |  |  |  |  |  |  |  |  |
|  | E | **Electrical** |  |  |  |  |  |  |  |  |  |  |  |  |  |  |  |  |  |  |  |  |  |  |  |  |  |  |  |  |  |  |  |  |  |  |  |  |  |  |  |  |  |  |  |  |  |  |  |  |  |  |  |  |
|  | J | **Instrumentation** |  |  |  |  |  |  |  |  |  |  |  |  |  |  |  |  |  |  |  |  |  |  |  |  |  |  |  |  |  |  |  |  |  |  |  |  |  |  |  |  |  |  |  |  |  |  |  |  |  |  |  |  |
|  | S | **Safety & Environment** |  |  |  |  |  |  |  |  |  |  |  |  |  |  |  |  |  |  |  |  |  |  |  |  |  |  |  |  |  |  |  |  |  |  |  |  |  |  |  |  |  |  |  |  |  |  |  |  |  |  |  |  |
|  | W | **Painting** |  |  |  |  |  |  |  |  |  |  |  |  |  |  |  |  |  |  |  |  |  |  |  |  |  |  |  |  |  |  |  |  |  |  |  |  |  |  |  |  |  |  |  |  |  |  |  |  |  |  |  |  |
|  | V | **Insulation** |  |  |  |  |  |  |  |  |  |  |  |  |  |  |  |  |  |  |  |  |  |  |  |  |  |  |  |  |  |  |  |  |  |  |  |  |  |  |  |  |  |  |  |  |  |  |  |  |  |  |  |  |
|  | 07 | **CA17 - Connection Piperack - CA17 to CA51/CA12** |  |  | 2010-09-28 | 2012-08-10 |  |  |  |  |  |  |  |  |  |  |  |  |  |  |  |  |  |  |  |  |  |  |  |  |  |  |  |  |  |  |  |  |  |  |  |  |  |  |  |  |  |  |  |  |  |  |  |  |
|  | C | **Civil Work** |  |  | 2010-09-28 | 2012-04-30 |  |  |  |  |  |  |  |  |  |  |  |  |  |  |  |  |  |  |  |  |  |  |  |  |  |  |  |  |  |  |  |  |  |  |  |  |  |  |  |  |  |  |  |  |  |  |  |  |
| XC201707 |  | CA17 SR1707 - Concrete Works Piperack CA17/CA12 |  | 84d | 2010-09-28 A | 2011-01-29 A | EC28170704 (other project) FS+10d, EC45170715 (other project), EC28170710 (other project) FS+10d, EC45170705 (other project) FF+10d, XC151700 | 100% | 2010-09-28 | 2011-01-26 |  |  |  | TB26 - 3 - Construct-winter 7days * | Concrete works [50 cbm]; Concrete works [1500 h] | 461.93 |  | 1500,00 |  |  |  |  |  | XC201707 | 1500 | 1500 |  | 934 | 17 | 200 | 200 | C | MO03 | X | C | XC20 | 1707 | C | 17 | X | mis | LND | 1707 | MO11 |  |  |  |  |  |  |  |  |  |  |
| XC801710 |  | CA17 ExtrBldgFl1 SK1701 - Fire Proofing Steel Structure 1st Floor |  | 60d | 2011-09-12 | 2011-11-29 | XN201710, XC40171020, IMS-C-000130 SS, IMS-C-000130 FF, IMS-C-000135 FS+6d |  |  |  | 82d | 0d |  | TB26 - T - Construct-Winter-3 (Dec/Jan/Feb free) * | Fire proofing [850 sqm]; Fire proofing [6375 h] | 14,057.45 |  | 6375,00 |  |  |  |  |  | XC801710 | 6375 | 0 |  | 934 | 17 | 200 | 200 | C | CiC | X | C | XC80 | 1710 | C | 17 | X | FP | LND | 1710 | KRILAK |  |  |  |  |  |  |  |  | 1 | MTA |
| XC301707 |  | CA17 SR1707 - UG Installation (incl. Precast Manholes) |  | 60d | 2011-09-22 | 2011-11-21 | XC300C00, EC301707 (other project), XC300C10, XC201707, XC310C00, P3R02S1 (other project), ER441707 (other project), P3R02AS1 (other project), P3C02D4 (other project) FS+30d, P3R02S1 (other project) FF, P3R02BS (other project) |  |  |  | 9d | 16d |  | TB26 - 3 - Construction Normal 7days * CA17 |  |  |  |  |  |  |  |  |  | XC301707 | 0 | 0 |  | 934 | 17 | 200 | 200 | C | CiC | X | C | XC30 | 1707 | C | 17 | X | mis | LND | 1707 |  |  |  |  |  |  |  |  |  | 1 |  |
| XC191707 |  | CA17 SR1707 - Backfill |  | 30d | 2011-10-18 | 2012-03-01 | XC911707 FF+20d, XC301707 FF+10d, XC301707 SS+10d |  |  |  | 36d | 0d |  | TB26 - T - Construct-Winter-3 (Dec/Jan/Feb free) * | Backfill & Compaction [1150 cbm]; Backfill & Compaction [1725 h] | 103,500 |  | 1725,00 |  |  |  |  |  | XC191707 | 1725 | 0 |  | 934 | 17 | 200 | 200 | C | CiC | X | C | XC19 | 1707 | C | 17 | X | mis | LND | 1707 | MO11 |  |  |  |  |  |  |  |  |  |  |
| XC801704 |  | CA17 SK1704 - Fire Proofing |  | 46d | 2012-03-01 | 2012-04-30 | XN201704, IMS-C-000135 |  |  |  | 50d | 112.5d |  | TB26 - T - Construct-Winter-3 (Dec/Jan/Feb free) * | Fire proofing [1650 sqm]; Fire proofing [12375 h] | 14,057.45 |  | 12375,00 |  |  |  |  |  | XC801704 | 12375 | 0 |  | 934 | 17 | 200 | 200 | C | CiC | X | C | XC80 | 1704 | C | 17 | X | FP | LND | 1704 | KRILAK |  |  |  |  |  |  |  |  | 1 |  |

Notes:
- XE701700: UDF_PREDECESSOR: XE40, DEL XC60 Civil 100%, HVAC ducts, Finishing works partly
- XE921700: Scope: FDS - 61external sensors / GDS - 91 external sensors / Structured Cable System (SCS) / FOCL / DS + SAME / MDCN
- XE961700: Scope: FDS - 61external sensors / GDS - 91 external sensors / Structured Cable System (SCS) / FOCL / DS + SAME / MDCN
- XN711704: Scope: 09.02.2011: weight: 200 ton
- XN711705: Scope: 09.02.2011: weight: 120 ton
- XN711706: Scope: 09.02.2011: weight: 120 ton
- XN711709: Scope: 09.02.2011: weight: 65 ton
- XC801710: Current Status: 20110530 (O.Siegel): die / Vertragsverhandlung ist am 30.05.2011. Bis die Vertragliche Detail geklдrt / werden und die Firma MobilisierungsmaЯnahmen getroffen hat, wird es Mitte Juli / sein. / Scope: SK1701 (insgesamt): / No. of beams/ columns: 406 (fire Resistance R90/R120) / Length 3666,07 m; Weight: 1076631,93 kg; Surface Area 11019,32 / sqm
- XC301707: Current Status: 12.0.2011 (O. Siegel): nach Rьcksprache mit MO11 am 11 und / 12.Januar 11, wurde der 25-April-11 als Starttermin besprochen.
- XC801704: Current Status: 20110530 (O.Siegel): die / Vertragsverhandlung ist am 30.05.2011. Bis die Vertragliche Detail geklдrt / werden und die Firma MobilisierungsmaЯnahmen getroffen hat, wird es Mitte Juli / sein. / Scope: SK1701 (insgesamt): / No. of beams/ columns: 406 (fire Resistance R90/R120) / Length 3666,07 m; Weight: 1076631,93 kg; Surface Area 11019,32 / sqm

| ID | WBS | Activity | Type | Duration | Start | Finish | Predecessors | Complete | Total float | Free float | Constraint | Calendar | Resources | Cost | Actual cost | TB26 Ressource Budget | UDF_SAVE ACT ID | UDF_CHECK BASELINE | UDF_BUDGETED LABOR UNIT | UDF_ACTUAL LABOR UNIT | Department | Type of Work | Constr. Area | PMT-Area | PMT-Schedule Org | PMT-Phase | PMT-Respons. | Zeigen/n. Zeigen | WBS Phase | WBS Discipline | WBS Type of Work | WBS Objects | Russia WBS Discipline (Russia) | Russia Construction Area | Russia WBS Phase | IMS | UPT | Russia WBS Objects | UDF_CONTRACT START DATE | UDF_CONTRACT FINISH DATE | UDF_CONTRACT ITEM | TB26 Semantics | Inquiry/Order No | Subcontractor | UDF_COMMENTS | UDF_PLANNED START | UDF_PLANNED FINISH | UDF_CHECK CRITICAL PATH | UDF_CONTRACT FINISH DATE REV1 | UDF_CONTRACT START DATE REV1 | UDF_INDICATOR | TB26 Material Res Values | UDF_ELECTRICAL START | UDF_ELECTRICAL FINISH | UDF_Vendor Representatives |
| --- | --- | --- | --- | --- | --- | --- | --- | --- | --- | --- | --- | --- | --- | --- | --- | --- | --- | --- | --- | --- | --- | --- | --- | --- | --- | --- | --- | --- | --- | --- | --- | --- | --- | --- | --- | --- | --- | --- | --- | --- | --- | --- | --- | --- | --- | --- | --- | --- | --- | --- | --- | --- | --- | --- | --- |
|  | N | **Structural Steel** |  |  | 2011-03-27 | 2012-02-20 |  |  |  |  |  |  |  |  |  |  |  |  |  |  |  |  |  |  |  |  |  |  |  |  |  |  |  |  |  |  |  |  |  |  |  |  |  |  |  |  |  |  |  |  |  |  |  |  |  |
| XN701707 |  | CA17 SK1707 - KMD Assy Drawings | milestone | 0d | 2011-03-27 A | 2011-03-27 A |  | 100% |  |  | finish on or after 2011-03-17 | TB26 - 3 - Construction Normal 7days * CA17 |  |  |  | 22t | XN701707 | x | 0 | 0 | 934 | XNK | 17 | 200 | 200 | C | LND | KMD | X | N | XN05 | 1707 | N | 17 | X | SS | LND | 1707 |  |  |  |  |  |  |  |  |  |  |  |  |  |  |  |  |  |
| XN711707 |  | CA17 SK1707 - Steel Deliveries | milestone | 0d | 2011-03-27 A | 2011-03-27 A |  | 100% |  |  | finish on 2011-03-25 | TB26 - 3 - Construction Normal 7days * CA17 |  |  |  | 22t | XN711707 |  | 0 | 0 | 934 | XNK | 17 | 200 | 200 | C | LND | SD | X | N | XN06 | 1707 | N | 17 | X | SS | LND | 1707 |  |  |  |  |  |  |  |  |  |  |  |  |  |  |  |  |  |
| XN201707l |  | CA17 SK1707 - Installation Steel Structure (lower part) |  | 10d | 2011-12-31 | 2012-01-16 | XN701707, XN711707 FS+10d, XC201707, XN201718, XN201720 FS-30d, P3N02VN (other project), XN201736 |  | -161d | 0d |  | TB26 - 3 - Construction Normal 7days * CA17 | Piperacks, Main structures [1530 h]; Piperacks, Main Structures [36 t] | 2,660.72 |  | 1530,00 | XN201707l |  | 1530 | 0 | 934 | PU10 | 17 | 200 | 200 | C | LND |  | X | N | XN20 | 1707 | N | 17 | X | SS | LND | 1707 | 2011-03-01 | 2011-04-15 | E-04-11 | t | 2DC8990 | SM |  |  |  |  |  |  |  |  |  |  |  |
| XN251707 |  | CA17 SK1707 - Installation fireproof castables |  | 5d | 2012-01-17 | 2012-01-21 | XN201707l |  | -161d | 0d |  | TB26 - 3 - Construction Normal 7days * CA17 |  |  |  |  | XN251707 |  | 0 | 0 | 934 | PU10 | 17 | 200 | 200 | C | LND |  | X | N | XN20 | 1707 | N | 17 | X | SS | LND | 1707 |  |  |  |  | 2DC8990 | MO11 | action by MO11 |  |  |  |  |  |  |  |  |  |  |
| XN201707u |  | CA17 SK1707 - Installation Steel Structure (upper part) |  | 10d | 2012-01-22 | 2012-01-31 | XC201707, P3N02VN (other project), XN251707, XN701707, XN711707 |  | -161d | 0d |  | TB26 - 3 - Construction Normal 7days * CA17 | Piperacks, Main structures [1402.5 h]; Piperacks, Main Structures [33 t] | 2,660.72 |  | 1402,50 | XN201707u |  | 1402,5 | 0 | 934 | PU10 | 17 | 200 | 200 | C | LND |  | X | N | XN20 | 1707 | N | 17 | X | SS | LND | 1707 |  |  |  | t | 2DC8990 | SM |  |  |  |  |  |  |  |  |  |  |  |
| XN401707 |  | CA17 SK1707 - Install Railings,Ladders,etc. |  | 20d | 2012-01-22 | 2012-02-10 | XN201707l FS-10d, XN201707u FS-10d |  | -161d | 0d |  | TB26 - 3 - Construction Normal 7days * CA17 | Ladders & platforms [4 t]; Ladders & platforms [400 h] | 155.21 |  | 400,00 | XN401707 |  | 400 | 0 | 934 | XNK | 17 | 200 | 200 | C | LND |  | X | N | XN40 | 1707 | N | 17 | X | SS | LND | 1707 |  |  |  |  |  | SM |  |  |  |  |  |  |  |  |  |  |  |
| XN601707 |  | CA17 SK1707 - Install Gratings |  | 30d | 2012-01-22 | 2012-02-20 | EN641707 (other project), EN671707 (other project), XN401707 FF+10d |  | -161d | 0d |  | TB26 - 3 - Construction Normal 7days * CA17 | Grating [25 sqm]; Grating [93.75 h] | 1,552.08 |  | 93,75 | XN601707 |  | 93,75 | 0 | 934 | XNK | 17 | 200 | 200 | C | LND |  | X | N | XN60 | 1707 | N | 17 | X | SS | LND | 1707 |  |  |  |  |  | SM |  |  |  |  |  |  |  |  |  |  |  |
|  | H | **HVAC** |  |  |  |  |  |  |  |  |  |  |  |  |  |  |  |  |  |  |  |  |  |  |  |  |  |  |  |  |  |  |  |  |  |  |  |  |  |  |  |  |  |  |  |  |  |  |  |  |  |  |  |  |  |
|  | U | **Package Units** |  |  |  |  |  |  |  |  |  |  |  |  |  |  |  |  |  |  |  |  |  |  |  |  |  |  |  |  |  |  |  |  |  |  |  |  |  |  |  |  |  |  |  |  |  |  |  |  |  |  |  |  |  |
|  | B | **Mechanical - Stationary Equipment** |  |  |  |  |  |  |  |  |  |  |  |  |  |  |  |  |  |  |  |  |  |  |  |  |  |  |  |  |  |  |  |  |  |  |  |  |  |  |  |  |  |  |  |  |  |  |  |  |  |  |  |  |  |
|  | M | **Mechanical - Rotating Equipment** |  |  |  |  |  |  |  |  |  |  |  |  |  |  |  |  |  |  |  |  |  |  |  |  |  |  |  |  |  |  |  |  |  |  |  |  |  |  |  |  |  |  |  |  |  |  |  |  |  |  |  |  |  |
|  | R | **Piping** |  |  | 2012-01-12 | 2012-04-22 |  |  |  |  |  |  |  |  |  |  |  |  |  |  |  |  |  |  |  |  |  |  |  |  |  |  |  |  |  |  |  |  |  |  |  |  |  |  |  |  |  |  |  |  |  |  |  |  |  |
| XR201707 |  | CA17 SR1707 - Piping Prefabrication |  | 30d | 2012-01-12 | 2012-02-10 | ER49170705 (other project) SS+18d, ER491707 (other project) SS+18d, XR500C00 FS+15d |  | -161d | 0d | as late as possible | TB26 - 3 - Construction Normal 7days * CA17 | A/G piping prefabrication [1250 Fpi]; A/G Piping (Prefab) [4687.5 h] | 10,602.22 |  | 4687,50 | XR201707 |  | 4687,5 | 0 | 934 |  | 17 | 200 | 200 | C | LND |  | X | R | XR20 | 1707 | R | 17 | X | PRP | LND | 1707 |  |  |  |  |  |  |  |  |  |  |  |  |  |  |  |  |  |
| XR401707 |  | CA17 SR1707 - Piping Installation |  | 50d | 2012-02-11 | 2012-04-02 | XN201707u, P3J02S (other project) FF+20d, IMS-C-000190 FF, P3J02AS (other project), XN601707 SS+20d, P3R07AS1 (other project), P3J04IS (other project), XN201707l, P3R03AS1 (other project) FF+20d, P3R04S1 (other project) FF+20d, XR201707 SS+30d, P3R03BS1 (other project) FF+20d, P3J01AS (other project) FF+20d, P3J04CS1 (other project) |  | -161d | 0d |  | TB26 - 3 - Construction Normal 7days * CA17 | A/G piping field installation [1525 Fpi]; A/G Piping (Field) [9531.25 h] | 37,693.49 |  | 9531,25 | XR401707 |  | 9531,25 | 0 | 934 |  | 17 | 200 | 200 | C | LND |  | X | R | XR40 | 1707 | R | 17 | X | PI | LND | 1707 | 2011-02-25 |  | E-06-03-07 |  |  |  |  | 2011-05-12 |  |  |  |  |  |  |  |  |  |
| XR601707 |  | CA17 SR1707 - Piping Pressure Tests |  | 25d | 2012-03-19 | 2012-04-12 | XR401707 FF+10d |  | -15d | 0d |  | TB26 - 3 - Construction Normal 7days * CA17 |  |  |  | 435 | XR601707 |  | 0 | 0 | 934 |  | 17 | 200 | 200 | C | LND |  | X | R | XR60 | 1707 | R | 17 | X | HY | LND | 1707 |  |  | E-06-03-07 |  |  |  |  |  |  |  |  |  |  |  |  |  |  |
| XR801707 |  | CA17 SR1707 - Piping Reinstatement |  | 15d | 2012-04-08 | 2012-04-22 | XR601707 FF+10d, IMS-C-000360 FF |  | -15d | 0d |  | TB26 - 3 - Construction Normal 7days * CA17 |  |  |  | 218 | XR801707 |  | 0 | 0 | 934 |  | 17 | 200 | 200 | C | LND |  | X | R | XR80 | 1707 | R | 17 | X | PI | LND | 1707 |  | 2012-02-25 | E-06-03-07 |  |  |  |  |  | 2012-05-11 | XR801707 |  |  |  |  |  |  |  |
|  | E | **Electrical** |  |  | 2010-09-28 | 2012-08-10 |  |  |  |  |  |  |  |  |  |  |  |  |  |  |  |  |  |  |  |  |  |  |  |  |  |  |  |  |  |  |  |  |  |  |  |  |  |  |  |  |  |  |  |  |  |  |  |  |  |
| XC911707 |  | CA17 SR1707 - Installation Earthing&Lightn.Sys_CIVIL |  | 25d | 2010-09-28 A | 2010-10-22 A | EE901707 (other project), XC201707 FF+5d | 100% |  |  |  | TB26 - 3 - Construct-winter 7days * | Grounding & Lightning [100 pcs]; Grounding & Lightning [1125 h] | 45,000 | 45,000 | 1125,00 | XC911707 |  | 1125 | 1125 | 934 |  | 17 | 200 | 200 | C | LND |  | X | C | XE91 | 1707 | C | 17 | X | EA | LND | 1707 |  |  |  |  |  | MO11 |  |  |  |  |  |  |  |  |  |  |  |
| XE911717 |  | CA17 SR1707 - Installation Earthing&Lightn.Sys_E/I |  | 5d | 2012-02-01 | 2012-02-08 | XN201707u, XN201707u FF |  | 125d | 236.5d |  | TB26 - 3 - Construct-winter 7days * |  |  |  | 115 | XE911717 |  | 0 | 0 | 934 |  | 17 | 200 | 200 | C | LND |  | X | E | XE91 | 1707 | E | 17 | X | EA | LND | 1707 |  |  |  |  |  | URMA |  |  |  |  | 2012-04-01 | 2011-09-20 | UDF_G3 |  |  |  |  |
| XE401707 |  | CA17 SR1707 - Install Cable Trays |  | 20d | 2012-03-09 | 2012-04-05 | XN201707l, XN201707u, EE46170710 (other project), XR401707 FS-25d |  | -95d | 0d |  | TB26 - V - Construct-Winter partly * | Cable trays/conduits [160 m]; Cable trays [480 h] | 19,200 |  | 480,00 | XE401707 | x | 480 | 0 | 934 |  | 17 | 200 | 200 | C | LND |  | X | E | XE40 | 1707 | E | 17 | X | EL | LND | 1707 | 2011-06-10 | 2011-11-30 | E-15-01-11 | m |  | URMA |  |  |  |  | 2012-04-01 | 2011-09-20 | UDF_G3 | 400 | 2011-08-21 | 2011-09-24 |  |
| XE801707 |  | CA17 SR1707 - Install Heat Tracing |  | 15d | 2012-05-14 | 2012-05-29 | RF-21408, XW501707 FF+20d, RF-21407, XR601707 FS-10d, P3E19S (other project), RF-21405, E3E1950 (other project) |  | -16d | 0d |  | TB26 - 3 - Construction Normal 7days * CA17 | Electrical Heat Tracing [300 m]; Electrical heat tracing [150 h] | 6,000 |  | 150,00 | XE801707 |  | 150 | 0 | 934 |  | 17 | 200 | 200 | C | LND |  | X | E | XE80 | 1707 | E | 17 | X | HT | LND | 1707 | 2011-06-20 | 2012-03-20 | E-16-04-01 |  |  | URMA |  |  |  |  | 2012-06-30 | 2011-09-15 | UDF_G3 |  |  |  | 005 |
| XE501707 |  | CA17 SR1707 - Cable Pulling Electric |  | 50d | 2012-06-13 | 2012-08-10 | XE505103 SS+12d, EE561707 (other project), XE401707 SS+20d, XE500C01 |  | -83.5d | 0d |  | TB26 - V - Construct-Winter partly * | Cable Pulling [10200 m]; Cable pulling [5100 h] | 204,000 |  | 5100,00 | XE501707 |  | 5100 | 0 | 934 |  | 17 | 200 | 200 | C | LND |  | X | E | XE50 | 1707 | E | 17 | X | EL | LND | 1707 | 2011-05-20 | 2012-02-10 | E-16-01-01 | m |  | URMA |  |  |  |  | 2012-07-01 | 2011-10-01 | UDF_G3 | 10500 | 2011-09-10 | 2011-10-29 |  |
|  | J | **Instrumentation** |  |  | 2012-03-23 | 2012-07-18 |  |  |  |  |  |  |  |  |  |  |  |  |  |  |  |  |  |  |  |  |  |  |  |  |  |  |  |  |  |  |  |  |  |  |  |  |  |  |  |  |  |  |  |  |  |  |  |  |  |
| XJ421707 |  | CA17 SK1707 - Install CableTrays Instrumentation |  | 15d | 2012-03-23 | 2012-04-11 | XE401707 FS-10d, EJ46170710 (other project), XR401707 FS-20d |  | -39d | 50.5d |  | TB26 - V - Construct-Winter partly * | Secondary cable trays [240 m]; Install secondary cable trays [900 h] | 36,000 |  | 900,00 | XJ421707 |  | 900 | 0 | 934 |  | 17 | 200 | 200 | C | LND |  | X | J | XJ42 | 1707 | J | 17 | X | IN | LND | 1707 | 2011-06-10 | 2011-11-30 | E-15-01-11 | m |  | URMA |  |  |  |  | 2012-04-01 | 2011-09-20 | UDF_G3 | 350 | 2011-08-21 | 2011-09-24 |  |
| XJ521707 |  | CA17 SR1707 - Pulling Instrument Cables |  | 30d | 2012-06-13 | 2012-07-18 | XJ525102 SS+22d, XE500C01, P3J17S1 (other project), XJ421707, XE401707 |  | -89.5d | 0d |  | TB26 - V - Construct-Winter partly * | Multicore cables [3600 m]; Pull multicore cables [1800 h] | 72,000 |  | 1800,00 | XJ521707 |  | 1800 | 0 | 934 |  | 17 | 200 | 200 | C | LND |  | X | J | XJ52 | 1707 | J | 17 | X | IN | LND | 1707 |  |  |  | m |  | URMA |  |  |  |  |  |  | UDF_G2 | 2600 | 2011-09-10 | 2011-10-09 |  |

Notes:
- XN711707: Scope: 09.02.2011: weight: 72 ton
- XE911717: UDF_PREDECESSOR: XN30, DEL XE40, DEL XE80, DEL XJ40, Civil 100%, Equipment 100%
- XE401707: Current Status: 20110705 (O.Siegel): keine / Verknьpfung zu Piping, da auf unterschiedlichen Ebenen gearbeitet wird, so dass / auch keine Behinderungen/ Beschдdigungen zu erwarten sind. / UDF_PREDECESSOR: XN20, Piping 50%
- XE801707: UDF_PREDECESSOR: XR40, Piping 50% pressure tests
- XE501707: UDF_PREDECESSOR: XE40, XE50, DEL XE34
- XJ421707: UDF_PREDECESSOR: XE40, XJ32, Equipment 100%, Piping 50%
- XJ521707: UDF_PREDECESSOR: XE40, XJ32, XJ52

| ID | WBS | Activity | Type | Duration | Start | Finish | Predecessors | Complete | Total float | Free float | Constraint | Calendar | Resources | Cost | TB26 Ressource Budget | UDF_SAVE ACT ID | UDF_BUDGETED LABOR UNIT | UDF_ACTUAL LABOR UNIT | Department | Constr. Area | PMT-Area | PMT-Schedule Org | PMT-Phase | PMT-Respons. | WBS Phase | WBS Discipline | WBS Type of Work | WBS Objects | Russia WBS Discipline (Russia) | Russia Construction Area | Russia WBS Phase | IMS | UPT | Russia WBS Objects | UDF_CONTRACT FINISH DATE | UDF_CONTRACT ITEM | Subcontractor | UDF_Concrete | UDF_CHECK BASELINE | UDF_CHECK CRITICAL PATH | Type of Work | Zeigen/n. Zeigen | Comments | UDF_Text4 | TB26 Semantics | Inquiry/Order No | UDF_CONTRACT DATE PENALIZED | UDF_PENALIZED START | UDF_PENALIZED FINISH |
| --- | --- | --- | --- | --- | --- | --- | --- | --- | --- | --- | --- | --- | --- | --- | --- | --- | --- | --- | --- | --- | --- | --- | --- | --- | --- | --- | --- | --- | --- | --- | --- | --- | --- | --- | --- | --- | --- | --- | --- | --- | --- | --- | --- | --- | --- | --- | --- | --- | --- |
|  | S | **Safety & Environment** |  |  |  |  |  |  |  |  |  |  |  |  |  |  |  |  |  |  |  |  |  |  |  |  |  |  |  |  |  |  |  |  |  |  |  |  |  |  |  |  |  |  |  |  |  |  |  |
|  | W | **Painting** |  |  | 2012-03-29 | 2012-05-03 |  |  |  |  |  |  |  |  |  |  |  |  |  |  |  |  |  |  |  |  |  |  |  |  |  |  |  |  |  |  |  |  |  |  |  |  |  |  |  |  |  |  |  |
| XW501707 |  | CA17 SR1707 - Surf.Protection Piping |  | 30d | 2012-03-29 | 2012-05-03 | XR201707 SS, XR801707 FF+10d |  | -13d | 0d |  |  | Piping painting [1056 sqm]; Piping painting [2640 h] | 1,921.63 | 2640,00 | XW501707 | 2640 | 0 | 934 | 17 | 200 | 200 | C | LND | X | W | XW50 | 1707 | W | 17 | X | PA | LND | 1707 |  |  |  |  |  |  |  |  |  |  |  |  |  |  |  |
|  | V | **Insulation** |  |  | 2012-05-24 | 2012-07-13 |  |  |  |  |  |  |  |  |  |  |  |  |  |  |  |  |  |  |  |  |  |  |  |  |  |  |  |  |  |  |  |  |  |  |  |  |  |  |  |  |  |  |  |
| XV501707 |  | CA17 SR1707 - Insulation Piping |  | 50d | 2012-05-24 | 2012-07-13 | XE801707 SS+10d, XE801707 FF+20d |  | -16d | 0d |  | TB26 - 3 - Construction Normal 7days * CA17 | Piping insulation [900 sqm]; Piping insulation [6750 h] | 7,296.28 | 6750,00 | XV501707 | 6750 | 0 | 934 | 17 | 200 | 200 | C | LND | X | V | XV50 | 1707 | V | 17 | X | INS | LND | 1707 | 2012-04-30 | E-13-01 |  |  |  |  |  |  |  |  |  |  |  |  |  |
|  | 08 | **CA17 - Connection Piperack - CA17 to CA51/CA13** |  |  | 2010-09-28 | 2012-09-10 |  |  |  |  |  |  |  |  |  |  |  |  |  |  |  |  |  |  |  |  |  |  |  |  |  |  |  |  |  |  |  |  |  |  |  |  |  |  |  |  |  |  |  |
|  | C | **Civil Work** |  |  | 2010-10-03 | 2012-06-30 |  |  |  |  |  |  |  |  |  |  |  |  |  |  |  |  |  |  |  |  |  |  |  |  |  |  |  |  |  |  |  |  |  |  |  |  |  |  |  |  |  |  |  |
| XC201708 |  | CA17 SR1708 - Concrete Works Piperack CA17/CA13 |  | 85d | 2010-10-03 A | 2011-02-07 A | EC28170810 (other project) FS+10d, EC28170804 (other project), XC151700, EC45170815 (other project), XC201707 SS+5d, EC45170805 (other project) FF+10d | 100% |  |  |  | TB26 - 3 - Construct-winter 7days * | Concrete works [50 cbm]; Concrete works [1500 h] | 461.93 | 1500,00 | XC201708 | 1500 | 1500 | 934 | 17 | 200 | 200 | C | MO03 | X | C | XC20 | 1708 | C | 17 | X | mis | LND | 1708 |  |  | MO11 |  |  |  |  |  |  |  |  |  |  |  |  |
| XC301708 |  | CA17 SR1708 - UG Installation (incl. Precast Manholes) |  | 60d | 2011-09-22 | 2011-11-21 | XC300C00 SS, P3R02BS (other project), P3C02D4 (other project) FS+30d, P3R02AS1 (other project), EC301708 (other project) FS+20d, P3R02S1 (other project), ER441708 (other project), XC300C00, XC310C00, XC201708 |  | 9d | 27d |  | TB26 - 3 - Construction Normal 7days * CA17 |  |  |  | XC301708 | 0 | 0 | 934 | 17 | 200 | 200 | C | CiC | X | C | XC30 | 1708 | C | 17 | X | mis | LND | 1708 |  |  |  | 1 |  |  |  |  |  |  |  |  |  |  |  |
| XC801718 |  | CA17 ExtrBldgFl2 SK1701 - Fire Proofing Steel Structure 2nd Floor |  | 60d | 2011-09-29 | 2012-03-21 | XC40171820 SS, XN201718, IMS-C-000130 SS, IMS-C-000130 FF, IMS-C-000135, XC801710 SS+15d |  | 82d | 177.5d |  | TB26 - T - Construct-Winter-3 (Dec/Jan/Feb free) * | Fire proofing [3150 sqm]; Fire proofing [23625 h] | 14,064.84 | 23625,00 | XC801718 | 23625 | 0 | 934 | 17 | 200 | 200 | C | CiC | X | C | XC80 | 1718 | C | 17 | X | FP | LND | 1718 |  |  | KRILAK | 1 |  |  |  |  |  |  |  |  |  |  |  |
| XC801720 |  | CA17 ExtrBldgFl3 SK1701 - Fire Proofing Steel Structure 3rd Floor |  | 60d | 2011-10-22 | 2012-04-16 | IMS-C-000130 FF, IMS-C-000130 SS, XN201720, XC40172020, IMS-C-000135 |  | 62d | 157.5d |  | TB26 - T - Construct-Winter-3 (Dec/Jan/Feb free) * | Fire proofing [3100 sqm]; Fire proofing [23250 h] | 930,000 | 23250,00 | XC801720 | 23250 | 0 | 934 | 17 | 200 | 200 | C | CiC | X | C | XC80 | 1720 | C | 17 | X | FP | LND | 1720 |  |  | KRILAK | 1 |  |  |  |  |  |  |  |  |  |  |  |
| XC191708 |  | CA17 SR1708 - Backfill |  | 20d | 2011-10-29 | 2012-03-01 | XC911708 FF+20d, XC301708 FF+10d, XC301708 SS+10d |  | 327.5d |  |  | TB26 - T - Construct-Winter-3 (Dec/Jan/Feb free) * | Backfill & Compaction [1150 cbm]; Backfill & Compaction [1725 h] | 103,500 | 1725,00 | XC191708 | 1725 | 0 | 934 | 17 | 200 | 200 | C | CiC | X | C | XC19 | 1708 | C | 17 | X | mis | LND | 1708 |  |  | MO11 |  |  |  |  |  |  |  |  |  |  |  |  |
| XC803110 |  | CA31 SiloStruc SK3101 - Fire Proofing Steel Structure |  | 107d | 2011-11-14 | 2012-06-30 | XN803110 FF-20d, XN803110 SS+10d, XN203110 FS-10d, XB50311010 FF, IMS-C-000130 SS, XB50311010, IMS-C-000130 FF, IMS-C-000135 |  | 47d | 117.5d |  | TB26 - T - Construct-Winter-3 (Dec/Jan/Feb free) * | Fire proofing [12200 sqm]; Fire proofing [91500 h] | 3,660,000 | 91500,00 | XC803110 | 91500 | 0 | 934 | 31 | 200 | 200 | C | CiC | X | C | XC80 | 3110 | C | 31 | X | FP | LND | 3110 |  |  | KRILAK | 1 | x |  |  |  |  |  |  |  |  |  |  |
| XC801730 |  | CA17 ExtrBldgFl4 SK1701 - Fire Proofing Steel Structure 4th Floor |  | 57d | 2012-03-01 | 2012-05-15 | XN201730 FS-5d, XC40173020 FS-15d, IMS-C-000130 SS, IMS-C-000130 FF, IMS-C-000135 |  | 39d | 134.5d |  | TB26 - T - Construct-Winter-3 (Dec/Jan/Feb free) * | Fire proofing [1650 sqm]; Fire proofing [12375 h] | 495,000 | 12375,00 | XC801730 | 12375 | 0 | 934 | 17 | 200 | 200 | C | CiC | X | C | XC80 | 1730 | C | 17 | X | FP | LND | 1730 |  |  | KRILAK | 1 |  |  |  |  |  |  |  |  |  |  |  |
| XC801736 |  | CA17 ExtrBldgFl5 SK1701 - Fire Proofing Steel Structure 5th Floor |  | 46d | 2012-03-01 | 2012-04-30 | XC40173620 FS-10d, XN201736, IMS-C-000135 |  | 50d | 145.5d |  | TB26 - T - Construct-Winter-3 (Dec/Jan/Feb free) * | Fire proofing [650 sqm]; Fire proofing [4875 h] | 195,000 | 4875,00 | XC801736 | 4875 | 0 | 934 | 17 | 200 | 200 | C | CiC | X | C | XC80 | 1736 | C | 17 | X | FP | LND | 1736 |  |  | KRILAK | 1 |  |  |  |  |  |  |  |  |  |  |  |
| XC803130 |  | CA31 Service Area SK3103 - Fire Proofing Steel Structure |  | 46d | 2012-03-01 | 2012-04-30 | XN803130 FF-20d, IMS-C-000130 SS, IMS-C-000130 FF, XN803130 SS+10d, XN203130, IMS-C-000135 |  | 50d | 145d | start on or after 2012-03-01 | TB26 - T - Construct-Winter-3 (Dec/Jan/Feb free) * |  |  | 300 | XC803130 | 4500 | 0 | 934 | 31 | 200 | 200 | C | CiC | X | C | XC80 | 3130 | C | 31 | X | FP | LND | 3110 |  |  | KRILAK | 1 | x |  |  |  |  |  |  |  |  |  |  |
| XC803120 |  | CA31 Blower Sec SK3104 - Fire Proofing Steel Structure |  | 40d | 2012-04-02 | 2012-05-19 | IMS-C-000130 FF, XN203120, IMS-C-000130 SS, XN803120 SS, IMS-C-000135 |  | 35d | 130d | start on or after 2012-04-02 | TB26 - T - Construct-Winter-3 (Dec/Jan/Feb free) * |  |  | 300 | XC803120 | 4500 | 0 | 934 | 31 | 200 | 200 | C | CiC | X | C | XC80 | 3120 | C | 31 | X | FP | LND | 3110 |  |  | KRILAK | 1 | x |  |  |  |  |  |  |  |  |  |  |
| XC803140 |  | CA31 Warehouse SK3102 - Fire Proofing Steel Structure |  | 75d | 2012-04-02 | 2012-06-30 | IMS-C-000130 FF, IMS-C-000130 SS, XN803140S FF-20d, XN203140, XN803140 SS+10d, IMS-C-000135 |  | 0d | 95d | start on or after 2012-04-02 | TB26 - T - Construct-Winter-3 (Dec/Jan/Feb free) * |  |  | 300 | XC803140 | 4500 | 0 | 934 | 31 | 200 | 200 | C | CiC | X | C | XC80 | 3140 | C | 31 | X | FP | LND | 3110 |  |  | KRILAK | 1 | x | XX120 |  |  |  |  |  |  |  |  |  |
|  | N | **Structural Steel** |  |  | 2011-04-21 | 2012-02-20 |  |  |  |  |  |  |  |  |  |  |  |  |  |  |  |  |  |  |  |  |  |  |  |  |  |  |  |  |  |  |  |  |  |  |  |  |  |  |  |  |  |  |  |
| XN701708 |  | CA17 SK1708 - KMD Assy Drawings | milestone | 0d | 2011-04-21 A | 2011-04-21 A |  | 100% |  |  | finish on 2011-04-21 | TB26 - 3 - Construction Normal 7days * CA17 |  |  | 22t | XN701708 | 0 | 0 | 934 | 17 | 200 | 200 | C | LND | X | N | XN05 | 1708 | N | 17 | X | SS | LND | 1708 |  |  |  |  | x |  | XNK | KMD |  |  |  |  |  |  |  |
| XN711708 |  | CA17 SK1708 - Steel Deliveries | milestone | 0d | 2011-05-01 A | 2011-05-01 A |  | 100% |  |  | finish on 2011-04-29 | TB26 - 3 - Construction Normal 7days * CA17 |  |  | 22t | XN711708 | 0 | 0 | 934 | 17 | 200 | 200 | C | LND | X | N | XN06 | 1708 | N | 17 | X | SS | LND | 1708 |  |  |  |  |  |  | XNK | SD |  |  |  |  |  |  |  |
| XN201708ll |  | CA17 SK1708 - Installation Steel Structure (after Heavy Lift) (lower part) |  | 10d | 2012-01-22 | 2012-01-31 | XC201708, XN701708, XB10176010, XB10176014, P3N02WN (other project), XN201707u SS, XN201707l SS, XN711708 FS+10d, XB10176012 |  | -99d | 0d |  | TB26 - 3 - Construction Normal 7days * CA17 | Piperacks, Main structures [1530 h]; Piperacks, Main Structures [36 t] | 2,660.72 | 1530,00 | XN201708ll | 1530 | 0 | 934 | 17 | 200 | 200 | C | LND | X | N | XN20 | 1708 | N | 17 | X | SS | LND | 1708 |  |  | SM |  |  |  | PU10 | C9 | CA17 Heavy Lift | CA17 - critical - CW5 | t | 2DC8990 |  |  |  |
| XN601708 |  | CA17 SK1708 - Install Gratings |  | 30d | 2012-01-22 | 2012-02-20 | EN641708 (other project), XN401708 FF |  | 398.5d |  |  | TB26 - 3 - Construction Normal 7days * CA17 | Grating [25 sqm]; Grating [93.75 h] | 1,552.08 | 93,75 | XN601708 | 93,75 | 0 | 934 | 17 | 200 | 200 | C | LND | X | N | XN60 | 1708 | N | 17 | X | SS | LND | 1708 |  |  | SM |  |  |  | XNK |  |  |  |  |  |  |  |  |
| XN251708 |  | CA17 SK1708 - Installation fireproof castables |  | 5d | 2012-02-01 | 2012-02-05 | XN201708ll |  | -99d | 0d |  | TB26 - 3 - Construction Normal 7days * CA17 |  |  |  | XN251708 | 0 | 0 | 934 | 17 | 200 | 200 | C | LND | X | N | XN20 | 1708 | N | 17 | X | SS | LND | 1708 |  |  | MO11 |  |  |  | PU10 | C9 | CA17 Heavy Lift | CA17 - critical - CW5 |  | 2DC8990 |  |  |  |
| XN401708 |  | CA17 SK1708 - Install Railings,Ladders,etc. |  | 20d | 2012-02-01 | 2012-02-20 | XN201708ll SS+10d |  | 398.5d | 0d |  | TB26 - 3 - Construction Normal 7days * CA17 | Ladders & platforms [4 t]; Ladders & platforms [400 h] | 155.21 | 400,00 | XN401708 | 400 | 0 | 934 | 17 | 200 | 200 | C | LND | X | N | XN40 | 1708 | N | 17 | X | SS | LND | 1708 |  |  | SM |  |  |  | XNK |  |  |  |  |  |  |  |  |
| XN201708u |  | CA17 SK1708 - Installation Steel Structure (after Heavy Lift) (upper part) |  | 10d | 2012-02-06 | 2012-02-15 | XN711708 FS+10d, XN251708, XN701708 |  | -99d | 3d |  | TB26 - 3 - Construction Normal 7days * CA17 | Piperacks, Main structures [1445 h]; Piperacks, Main Structures [34 t] | 2,660.72 | 1445,00 | XN201708u | 1445 | 0 | 934 | 17 | 200 | 200 | C | LND | X | N | XN20 | 1708 | N | 17 | X | SS | LND | 1708 |  |  | SM |  |  |  | PU10 | C9 | CA17 Heavy Lift | CA17 - critical - CW5 | t | 2DC8990 | P | 2012-02-29 | 2012-02-29 |

Notes:
- XW501707: P3 Activity Log Info: Clarification Surface / Protection during Prefab
- XC301708: P3 Activity Log Info: Clarification Heavy Lift Loads / Current Status: 12.0.2011 (O. Siegel): nach Rьcksprache mit MO11 am 11 und / 12.Januar 11, wurde der 25-April-11 als Starttermin besprochen.
- XC801718: Scope: SK1701 (insgesamt): / No. of beams/ columns: 406 (fire Resistance R90/R120) / Length 3666,07 m; Weight: 1076631,93 kg; Surface Area 11019,32 / sqm
- XC801720: Scope: SK1701 (insgesamt): / No. of beams/ columns: 406 (fire Resistance R90/R120) / Length 3666,07 m; Weight: 1076631,93 kg; Surface Area 11019,32 / sqm
- XC191708: P3 Activity Log Info: Clarification Heavy Lift Loads
- XC803110: Current Status: 20110530 (O.Siegel): Nach dem Steel Structure werden Supports fьr Cladding / angebracht. Danach wird Brandschutzanstrich aufgebracht werden. nachdem / Brandschutzanstrich fertig ist, braucht es noch 10 Tage, bis Cladding Arbeiten / aufnehmen kann. / Scope: SK3101: / No. of beams/ columns: 745 (fire Resistance R90) / Length 4692,61 m; Weight: 296671,25 kg; Surface Area 6734,09 / sqm
- XC801730: Scope: SK1701 (insgesamt): / No. of beams/ columns: 406 (fire Resistance R90/R120) / Length 3666,07 m; Weight: 1076631,93 kg; Surface Area 11019,32 / sqm
- XC801736: Scope: SK1701 (insgesamt): / No. of beams/ columns: 406 (fire Resistance R90/R120) / Length 3666,07 m; Weight: 1076631,93 kg; Surface Area 11019,32 / sqm
- XC803130: Current Status: 20110530 (O.Siegel): Nach dem Steel Structure werden Supports fьr Cladding / angebracht. Danach wird Brandschutzanstrich aufgebracht werden. nachdem / Brandschutzanstrich fertig ist, braucht es noch 10 Tage, bis Cladding Arbeiten / aufnehmen kann. / Scope: SK3103: / No. of beams/ columns: 17 (fire Resistance R90) / Length 280,34m; Weight: 31669,91 kg; Surface Area 781,39 / sqm
- XC803120: Current Status: 20110530 (O.Siegel): Nach dem Steel Structure werden Supports fьr Cladding / angebracht. Danach wird Brandschutzanstrich aufgebracht werden. nachdem / Brandschutzanstrich fertig ist, braucht es noch 10 Tage, bis Cladding Arbeiten / aufnehmen kann. / Scope: SK3104: / No. of beams/ columns: 33 (fire Resistance R90) / Length 445,46 m; Weight: 40234,41kg; Surface / Area 949,73sqm
- XC803140: Current Status: 20110530 (O.Siegel): Nach dem Steel Structure werden Supports fьr Cladding / angebracht. Danach wird Brandschutzanstrich aufgebracht werden. nachdem / Brandschutzanstrich fertig ist, braucht es noch 10 Tage, bis Cladding Arbeiten / aufnehmen kann. / Scope: SK3102: / No. of beams/ columns: 255 (fire Resistance R90) / Length 2311,79 m; Weight: 155340,81 kg; Surface Area 3709,85 / sqm
- XN711708: Scope: 09.02.2011: weight: 73 ton
- XN201708ll: Current Status: 110803 (WL): Delete PRED XC191708 CA17 SR1708 - Backfill
- XN251708: P3 Activity Log Info: Clarification Preassembly
- XN201708u: P3 Activity Log Info: Clarification Preassembly

| ID | WBS | Activity | Type | Duration | Start | Finish | Predecessors | Complete | Remaining | Planned start | Planned finish | Total float | Free float | Constraint | Calendar | Resources | Cost | Actual cost | TB26 Ressource Budget | UDF_Text4 | UDF_SAVE ACT ID | UDF_BUDGETED LABOR UNIT | UDF_ACTUAL LABOR UNIT | Department | Constr. Area | PMT-Area | PMT-Schedule Org | PMT-Phase | PMT-Respons. | WBS Phase | WBS Discipline | WBS Type of Work | WBS Objects | Russia WBS Discipline (Russia) | Russia Construction Area | Russia WBS Phase | IMS | UPT | Russia WBS Objects | UDF_CONTRACT START DATE | UDF_CONTRACT ITEM | UDF_PLANNED START | UDF_CONTRACT FINISH DATE | UDF_CONTRACT DATE PENALIZED | UDF_PLANNED FINISH | UDF_PENALIZED START | UDF_PENALIZED FINISH | Subcontractor | UDF_CONTRACT FINISH DATE REV1 | UDF_CONTRACT START DATE REV1 | TB26 Semantics | TB26 Material Res Values | UDF_ELECTRICAL START | UDF_ELECTRICAL FINISH | UDF_CHECK BASELINE | UDF_INDICATOR | Zeigen/n. Zeigen | UDF_Vendor Representatives | Inquiry/Order No | 4 week lookahead | UDF_SELECT UPDATE PROGRESS | Comments | Civil item | MTA | UDF_CONTRACT INDICATOR | UDF_CHECK RESOURCE DATES | UDF_SELECT | Check ResLoading | UDF_Concrete |
| --- | --- | --- | --- | --- | --- | --- | --- | --- | --- | --- | --- | --- | --- | --- | --- | --- | --- | --- | --- | --- | --- | --- | --- | --- | --- | --- | --- | --- | --- | --- | --- | --- | --- | --- | --- | --- | --- | --- | --- | --- | --- | --- | --- | --- | --- | --- | --- | --- | --- | --- | --- | --- | --- | --- | --- | --- | --- | --- | --- | --- | --- | --- | --- | --- | --- | --- | --- | --- | --- |
|  | H | **HVAC** |  |  |  |  |  |  |  |  |  |  |  |  |  |  |  |  |  |  |  |  |  |  |  |  |  |  |  |  |  |  |  |  |  |  |  |  |  |  |  |  |  |  |  |  |  |  |  |  |  |  |  |  |  |  |  |  |  |  |  |  |  |  |  |  |  |  |  |
|  | U | **Package Units** |  |  |  |  |  |  |  |  |  |  |  |  |  |  |  |  |  |  |  |  |  |  |  |  |  |  |  |  |  |  |  |  |  |  |  |  |  |  |  |  |  |  |  |  |  |  |  |  |  |  |  |  |  |  |  |  |  |  |  |  |  |  |  |  |  |  |  |
|  | B | **Mechanical - Stationary Equipment** |  |  |  |  |  |  |  |  |  |  |  |  |  |  |  |  |  |  |  |  |  |  |  |  |  |  |  |  |  |  |  |  |  |  |  |  |  |  |  |  |  |  |  |  |  |  |  |  |  |  |  |  |  |  |  |  |  |  |  |  |  |  |  |  |  |  |  |
|  | M | **Mechanical - Rotating Equipment** |  |  |  |  |  |  |  |  |  |  |  |  |  |  |  |  |  |  |  |  |  |  |  |  |  |  |  |  |  |  |  |  |  |  |  |  |  |  |  |  |  |  |  |  |  |  |  |  |  |  |  |  |  |  |  |  |  |  |  |  |  |  |  |  |  |  |  |
|  | R | **Piping** |  |  | 2012-01-27 | 2012-05-11 |  |  |  |  |  |  |  |  |  |  |  |  |  |  |  |  |  |  |  |  |  |  |  |  |  |  |  |  |  |  |  |  |  |  |  |  |  |  |  |  |  |  |  |  |  |  |  |  |  |  |  |  |  |  |  |  |  |  |  |  |  |  |  |
| XR201708 |  | CA17 SR1708 - Piping Prefabrication |  | 30d | 2012-01-27 | 2012-03-02 | ER49170805 (other project) SS+18d, ER491708 (other project) SS+18d, XR500C00 FS+15d |  |  |  |  | -88d | 0d | as late as possible |  | A/G piping prefabrication [1250 Fpi]; A/G Piping (Prefab) [4687.5 h] | 10,602.22 |  | 4687,50 | CA17 - critical - CW5 | XR201708 | 4687,5 | 0 | 934 | 17 | 200 | 200 | C | LND | X | R | XR20 | 1708 | R | 17 | X | PRP | LND | 1708 |  |  |  |  |  |  |  |  |  |  |  |  |  |  |  |  |  |  |  |  |  |  |  |  |  |  |  |  |  |  |
| XR401708 |  | CA17 SR1708 - Piping Installation |  | 50d | 2012-02-19 | 2012-04-17 | XN201708ll FS+10d, XN201708u, XR201708 SS+20d, IMS-C-000190 FF |  |  |  |  | -61d | 0d |  | TB26 - 3 - Construct-winter 7days * | A/G piping field installation [1525 Fpi]; A/G Piping (Field) [9531.25 h] | 37,693.49 |  | 9531,25 | CA17 - critical - CW5 | XR401708 | 9531,25 | 0 | 934 | 17 | 200 | 200 | C | LND | X | R | XR40 | 1708 | R | 17 | X | PI | LND | 1708 | 2011-02-25 | E-06-03-07 | 2011-05-12 |  |  |  |  |  |  |  |  |  |  |  |  |  |  |  |  |  |  |  |  |  |  |  |  |  |  |  |
| XR601708 |  | CA17 SR1708 - Piping Pressure Tests |  | 25d | 2012-03-30 | 2012-04-27 | XR401708 FF+10d |  |  |  |  | 16d | 0d |  |  |  |  |  | 435 | CA17 - critical - CW5 | XR601708 | 0 | 0 | 934 | 17 | 200 | 200 | C | LND | X | R | XR60 | 1708 | R | 17 | X | HY | LND | 1708 |  | E-06-03-07 |  |  |  |  |  |  |  |  |  |  |  |  |  |  |  |  |  |  |  |  |  |  |  |  |  |  |  |  |
| XR801708 |  | CA17 SR1708 - Piping Reinstatement |  | 15d | 2012-04-25 | 2012-05-11 | IMS-C-000360 FF, XR601708 FF+10d |  |  |  |  | 19d | 0d |  | TB26 - 3 - Construct-winter 7days * |  |  |  | 218 | CA17 - critical - CW5 | XR801708 | 0 | 0 | 934 | 17 | 200 | 200 | C | LND | X | R | XR80 | 1708 | R | 17 | X | PI | LND | 1708 |  | E-06-03-07 |  | 2012-02-25 | P | 2012-05-11 | 2012-05-31 | 2012-05-31 |  |  |  |  |  |  |  |  |  |  |  |  |  |  |  |  |  |  |  |  |  |  |
|  | E | **Electrical** |  |  | 2010-09-28 | 2012-07-30 |  |  |  |  |  |  |  |  |  |  |  |  |  |  |  |  |  |  |  |  |  |  |  |  |  |  |  |  |  |  |  |  |  |  |  |  |  |  |  |  |  |  |  |  |  |  |  |  |  |  |  |  |  |  |  |  |  |  |  |  |  |  |  |
| XC911708 |  | CA17 SR1708 - Installation Earthing&Lightn.Sys_CIVIL |  | 30d | 2010-09-28 A | 2010-10-27 A | XC201708 FF+5d, EE901708 (other project) | 100% |  |  |  |  |  |  | TB26 - 3 - Construct-winter 7days * | Grounding & Lightning [100 pcs]; Grounding & Lightning [1125 h] | 45,000 | 45,000 | 1125,00 |  | XC911708 | 1125 | 1125 | 934 | 17 | 200 | 200 | C | LND | X | C | XE91 | 1708 | C | 17 | X | EA | LND | 1708 |  |  |  |  |  |  |  |  | MO11 |  |  |  |  |  |  |  |  |  |  |  |  |  |  |  |  |  |  |  |  |  |
| XE911709 |  | CA17 SR1708 - Installation Earthing&Lightn.Sys_E/I |  | 5d | 2012-02-19 | 2012-02-26 | XN201708u |  |  |  |  | 116d | 227.5d |  | TB26 - 3 - Construct-winter 7days * |  |  |  | 115 |  | XE911709 | 0 | 0 | 934 | 17 | 200 | 200 | C | LND | X | E | XE91 | 1708 | E | 17 | X | EA | LND | 1708 |  |  |  |  |  |  |  |  | URMA | 2012-04-01 | 2011-09-20 |  |  |  |  |  |  |  |  |  |  |  |  |  |  |  |  |  |  |  |
| XE401708 |  | CA17 SR1708 - Install Cable Trays |  | 20d | 2012-03-22 | 2012-04-16 | XN201708u, EE46170810 (other project), XR401708 FS-25d |  |  |  |  | -48d | 0d |  | TB26 - V - Construct-Winter partly * | Cable trays/conduits [160 m]; Cable trays [480 h] | 19,200 |  | 480,00 |  | XE401708 | 480 | 0 | 934 | 17 | 200 | 200 | C | LND | X | E | XE40 | 1708 | E | 17 | X | EL | LND | 1708 | 2011-06-10 | E-15-01-11 |  | 2011-11-30 |  |  |  |  | URMA | 2012-04-01 | 2011-09-20 | m | 400 | 2011-11-23 | 2012-01-30 | x | UDF_G3 | C9 |  |  |  |  |  |  |  |  |  |  |  |  |
| XE801708 |  | CA17 SR1708 - Install Heat Tracing |  | 15d | 2012-05-27 | 2012-06-10 | XR601708 FS-10d, IMS-C-000280 FF, E3E1950 (other project), XW501708 SS+43d, XR401708 FS-15d |  |  |  |  | 19d | 37d |  | TB26 - 3 - Construct-winter 7days * | Electrical Heat Tracing [300 m]; Electrical heat tracing [150 h] | 6,000 |  | 150,00 | CA17 - critical - CW5 | XE801708 | 150 | 0 | 934 | 17 | 200 | 200 | C | LND | X | E | XE80 | 1708 | E | 17 | X | HT | LND | 1708 | 2011-06-20 | E-16-04-01 |  | 2012-03-20 |  |  |  |  | URMA | 2012-06-30 | 2011-09-15 |  |  |  |  |  | UDF_G3 |  | 005 |  |  |  |  |  |  |  |  |  |  |  |
| XE501708 |  | CA17 SR1708 - Cable Pulling Electric |  | 50d | 2012-05-31 | 2012-07-30 | XE505102 SS+12d, XE500C01, XE401708, EE561708 (other project) |  |  |  |  | -73.5d | 0d |  | TB26 - V - Construct-Winter partly * | Cable Pulling [10200 m]; Cable pulling [5100 h] | 204,000 |  | 5100,00 |  | XE501708 | 5100 | 0 | 934 | 17 | 200 | 200 | C | LND | X | E | XE50 | 1708 | E | 17 | X | EL | LND | 1708 | 2011-05-20 | E-16-01-01 |  | 2012-02-10 |  |  |  |  | URMA | 2012-07-01 | 2011-10-01 | m | 10500 | 2011-12-28 | 2012-03-21 |  | UDF_G3 |  |  |  |  |  |  |  |  |  |  |  |  |  |
|  | J | **Instrumentation** |  |  | 2012-04-05 | 2012-07-27 |  |  |  |  |  |  |  |  |  |  |  |  |  |  |  |  |  |  |  |  |  |  |  |  |  |  |  |  |  |  |  |  |  |  |  |  |  |  |  |  |  |  |  |  |  |  |  |  |  |  |  |  |  |  |  |  |  |  |  |  |  |  |  |
| XJ421708 |  | CA17 SK1708 - Install CableTrays Instrumentation |  | 15d | 2012-04-05 | 2012-04-21 | XE401708 FS-10d, EJ46170810 (other project), XR401708 FS-20d |  |  |  |  | -48d | 49.5d |  | TB26 - V - Construct-Winter partly * | Secondary cable trays [240 m]; Install secondary cable trays [900 h] | 36,000 |  | 900,00 |  | XJ421708 | 900 | 0 | 934 | 17 | 200 | 200 | C | LND | X | J | XJ42 | 1708 | J | 17 | X | IN | LND | 1708 | 2011-06-10 | E-15-01-11 |  | 2011-11-30 |  |  |  |  | URMA | 2012-04-01 | 2011-09-20 | m | 350 | 2011-11-23 | 2012-01-30 |  | UDF_G3 | C9 |  |  |  |  |  |  |  |  |  |  |  |  |
| XJ521708 |  | CA17 SR1708 - Pulling Instrument Cables |  | 30d | 2012-06-22 | 2012-07-27 | XJ421708, XJ525102 FS-20d, XE500C01, P3J17S1 (other project), XE401708 |  |  |  |  | -97.5d | 0d |  | TB26 - V - Construct-Winter partly * | Multicore cables [3600 m]; Pull multicore cables [1800 h] | 72,000 |  | 1800,00 |  | XJ521708 | 1800 | 0 | 934 | 17 | 200 | 200 | C | LND | X | J | XJ52 | 1708 | J | 17 | X | IN | LND | 1708 |  | E-17-04-07 |  |  |  |  |  |  | URMA | 2012-07-20 | 2011-10-15 | m | 2600 | 2012-01-16 | 2012-03-14 |  | UDF_G3 | C9 |  |  |  |  |  |  |  |  |  |  |  |  |
|  | S | **Safety & Environment** |  |  |  |  |  |  |  |  |  |  |  |  |  |  |  |  |  |  |  |  |  |  |  |  |  |  |  |  |  |  |  |  |  |  |  |  |  |  |  |  |  |  |  |  |  |  |  |  |  |  |  |  |  |  |  |  |  |  |  |  |  |  |  |  |  |  |  |
|  | W | **Painting** |  |  | 2012-04-05 | 2012-05-11 |  |  |  |  |  |  |  |  |  |  |  |  |  |  |  |  |  |  |  |  |  |  |  |  |  |  |  |  |  |  |  |  |  |  |  |  |  |  |  |  |  |  |  |  |  |  |  |  |  |  |  |  |  |  |  |  |  |  |  |  |  |  |  |
| XW501708 |  | CA17 SR1708 - Surf.Protection Piping |  | 30d | 2012-04-05 | 2012-05-11 | XR201708 SS, IMS-C-000200 FF, XR801708 FF |  |  |  |  | 16d | 0d |  |  | Piping painting [1056 sqm]; Piping painting [2640 h] | 1,921.63 |  | 2640,00 | CA17 - critical - CW5 | XW501708 | 2640 | 0 | 934 | 17 | 200 | 200 | C | LND | X | W | XW50 | 1708 | W | 17 | X | PA | LND | 1708 |  |  |  |  |  |  |  |  |  |  |  |  |  |  |  |  |  |  |  |  |  |  |  |  |  |  |  |  |  |  |
|  | V | **Insulation** |  |  | 2012-07-14 | 2012-09-10 |  |  |  |  |  |  |  |  |  |  |  |  |  |  |  |  |  |  |  |  |  |  |  |  |  |  |  |  |  |  |  |  |  |  |  |  |  |  |  |  |  |  |  |  |  |  |  |  |  |  |  |  |  |  |  |  |  |  |  |  |  |  |  |
| XV501708 |  | CA17 SR1708 - Insulation Piping |  | 50d | 2012-07-14 | 2012-09-10 | XV501707, XE801708 SS+10d, IMS-C-000210 FF |  |  |  |  | -14d | 81.5d | start on or after 2012-05-03 |  | Piping insulation [900 sqm]; Piping insulation [6750 h] | 7,296.28 |  | 6750,00 |  | XV501708 | 6750 | 0 | 934 | 17 | 200 | 200 | C | LND | X | V | XV50 | 1708 | V | 17 | X | INS | LND | 1708 |  | E-13-01 |  | 2012-04-30 |  |  | 2012-05-31 |  |  |  |  |  |  |  |  |  |  |  |  |  |  |  |  |  |  |  |  |  |  |  |
|  | 10 | **CA17 - Extrusion Bldg 1st Floor +0,15m** |  |  | 2010-04-23 | 2012-12-15 |  |  |  |  |  |  |  |  |  |  |  |  |  |  |  |  |  |  |  |  |  |  |  |  |  |  |  |  |  |  |  |  |  |  |  |  |  |  |  |  |  |  |  |  |  |  |  |  |  |  |  |  |  |  |  |  |  |  |  |  |  |  |  |
|  | C | **Civil Work** |  |  | 2010-04-23 | 2012-03-22 |  |  |  |  |  |  |  |  |  |  |  |  |  |  |  |  |  |  |  |  |  |  |  |  |  |  |  |  |  |  |  |  |  |  |  |  |  |  |  |  |  |  |  |  |  |  |  |  |  |  |  |  |  |  |  |  |  |  |  |  |  |  |  |
| XC111710 |  | CA17 ExtrBldgFl1 - Excavation |  | 27d | 2010-04-23 A | 2010-05-25 A | P3C01D1 (other project) | 100% |  |  |  |  |  |  |  | Excavation [4000 cbm]; Excavation [2000 h] | 160,000 | 160,000 | 2000,00 |  | XC111710 | 2000 | 2000 | 934 | 17 | 200 | 200 | C | MO02 | X | C | XC11 | 1710 | C | 10 | X | P | LND | 1010 |  |  |  |  |  |  |  |  | MO11 |  |  |  |  |  |  |  |  | C9-1 |  | 999 |  |  |  |  |  |  |  |  |  |  |
| XC11171010 |  | CA17 ExtrBldgFl1 - SubBase (Gravel/Geogrid) for Concrete |  | 20d | 2010-05-24 A | 2010-06-16 A | XC111710 | 100% |  | 2010-05-24 | 2010-06-15 |  |  |  |  | Sub Base for Concrete/Paving&Roads (Gravel) [3200 cbm]; Subbase for Concrete [3200 h] | 320,000 | 100,000 | 3200,00 |  | XC11171010 | 3200 | 3200 | 934 | 17 | 200 | 200 | C | MO02 | X | C | XC11 | 1710 | C | 10 | X | P | LND | 1010 |  |  |  |  |  |  |  |  | MO11 |  |  |  |  |  |  |  |  |  |  | 999 |  |  |  |  |  |  |  |  |  |  |
| XC151710 |  | CA17 ExtrBldgFl1 - Piling |  | 66d | 2010-06-21 A | 2010-09-04 A | F2910, XC111710, P3C01D1 (other project), XC11171010 FS+4d, EC151710 (other project) FS+5d | 100% |  |  |  |  |  |  |  | Piles driven [1089 pcs]; Piles driven [8167.5 h] | 326,700 | 326,700 | 8167,50 |  | XC151710 | 8167,5 | 8167,5 | 934 | 17 | 200 | 200 | C | MO02 | X | C | XC15 | 1710 | C | 17 | X | P | LND | 1710 |  |  |  |  |  |  |  |  | MO11 |  |  |  |  |  |  |  |  | C9-1 |  |  |  |  |  |  |  |  |  |  |  |  |
| XC20171005 |  | CA17 ExtrBldgFl1 - Concrete Works Baseplate |  | 35d | 2010-08-03 A | 2010-09-11 A | EC48171003 (other project) FS+7d, P3C02D1 (other project), XC151710 FS-33d, EC48171005 (other project) FF+10d | 100% |  |  |  |  |  |  | TB26 - V - Construct-Winter partly * | Concrete works [5860 cbm]; Concrete works [175800 h] | 7,032,000 | 7,032,000 | 175800,00 |  | XC20171005 | 175800 | 175800 | 934 | 17 | 200 | 200 | C | MO03 | X | C | XC20 | 1710 | C | 17 | X | mai | LND | 1710 |  |  |  |  |  |  |  |  | MO11 |  |  |  |  |  |  |  |  | C9-1 |  |  |  |  |  |  |  |  |  |  |  |  |
| XC20171007 |  | CA17 ExtrBldgFl1 - Concrete Works Baseplate finished | milestone | 0d | 2010-09-11 A | 2010-09-11 A | XC20171005 FF | 100% |  |  |  |  |  |  | TB26 - V - Construct-Winter partly * |  |  |  |  |  | XC20171007 | 0 | 0 | 934 | 17 | 200 | 200 | C | MO04 | X | C | XC20 | 1710 | C | 12 | X | mai | LND | 1201 |  |  |  |  |  |  |  |  | MO11 |  |  |  |  |  |  |  |  |  |  |  |  |  |  |  |  |  |  |  |  |  |
| XC40171010 |  | CA17 ExtrBldgFl1 - Concrete Works Columns <12m |  | 152d | 2010-09-26 A | 2011-04-23 A | P3C02D2 (other project), EC45170015 (other project) FF, EC48171005 (other project), XC20171005 FS+12d, EC45170005 (other project) FF+10d, XC20171007 FS+12d | 100% |  |  |  |  |  |  | TB26 - 3 - Construct-winter 7days * | Concrete works [920 cbm]; Concrete works [27600 h] | 22,690 |  | 27600,00 | CA17 - critical - CW5 | XC40171010 | 27600 | 27600 | 934 | 17 | 200 | 200 | C | MO04 | X | C | XC40 | 1710 | C | 17 | X | EB | LND | 1710 |  |  |  |  |  |  |  |  | MO11 |  |  |  |  |  |  |  |  | C9-1 |  |  | x |  |  |  |  |  |  |  |  |  |
| XC40171012 |  | CA17 ExtrBldgFl1 - Concrete Works Walls <12m (A-F/1-5) |  | 289d | 2010-09-26 A | 2011-05-13 A | EC45170005 (other project) FF+10d, XC40171010 FF+5d, EC48171006 (other project) FS+10d, EC45170015 (other project) FF | 100% |  | 2010-09-26 | 2011-09-10 |  |  |  | TB26 - 3 - Construct-winter 7days * | Concrete works [3310 cbm]; Concrete works [99300 h] | 22,690 |  | 0,00 | CA17 - critical - CW5 | XC40171012 | 99300 | 99300 | 934 | 17 | 200 | 200 | C | MO04 | X | C | XC40 | 1710 | C | 17 | X | EB | LND | 1710 |  |  |  |  |  |  |  |  | MO11 |  |  |  |  |  |  | x |  | C9-1 |  |  | x | x |  |  |  |  |  |  |  |  |
| XC40171005 |  | CA17 ExtrBldgFl1 - Precast Concrete Beams <12m |  | 83d | 2010-10-18 A | 2011-01-31 A | P3C02D2 (other project) FS+30d, EC48171004 (other project), EC48171010 (other project) FS+5d, XC20171005, EC45170005 (other project) SS+40d | 100% |  |  |  |  |  |  |  |  |  |  |  |  | XC40171005 | 0 | 0 | 934 | 17 | 200 | 200 | C | MO04 | X | C | XC40 | 1710 | C | 17 | X | pre | LND | 1710 |  |  |  |  |  |  |  |  | MO11 |  |  |  |  |  |  |  |  | C9 |  |  |  |  |  |  |  |  |  |  |  |  |
| XC40171015 |  | CA17 ExtrBldgFl1 - Erection Precast Beams/Stairtower Elements <12m |  | 52d | 2011-03-07 A | 2011-05-28 A | XC40171005 SS+40d, EC45170005 (other project) FF+10d, XC40171010 FS-8d | 100% |  | 2011-03-07 | 2011-05-01 |  |  | start on or after 2011-02-21 | TB26 - 3 - Construct-winter 7days * | Precast Concrete Works [690 cbm]; Precast concrete works [1725 h] | 69,000 | 69,000 | 1725,00 | CA17 - critical - CW5 | XC40171015 | 1725 | 1725 | 934 | 17 | 200 | 200 | C | MO04 | X | C | XC40 | 1710 | C | 17 | X | EB | LND | 1710 |  |  |  |  |  |  |  |  | MO11 |  |  | cbm |  |  |  |  |  | C9-1 |  |  | x | x |  |  |  |  |  |  |  |  |
| XC40171018 |  | CA17 ExtrBldgFl1 - ConcrWorks Columns <12m finished | milestone | 0d | 2011-04-01 A | 2011-04-01 A | XC40171010 FF | 100% |  |  |  |  |  |  |  |  |  |  |  |  | XC40171018 | 0 | 0 | 934 | 17 | 200 | 200 | C | MO04 | X | C | XC40 | 1710 | C | 17 | X | EB | LND | 1710 |  |  |  |  |  |  |  |  | MO11 |  |  |  |  |  |  |  |  |  |  |  | x |  |  |  |  |  |  |  |  |  |
| XC40171020 |  | CA17 ExtrBldgFl1 - Concrete Works Ceiling +12m |  | 36d | 2011-04-13 A | 2011-05-20 A | XC40171010 FS-15d, XC40171005, XC40171022 FF, EC48171020 (other project) FS+20d | 100% |  |  |  |  |  |  | TB26 - 3 - Construction Normal 7days * CA17 | Concrete works [630 cbm]; Concrete works [18900 h] | 13,924.42 |  | 18900,00 | CA17 - critical - CW5 | XC40171020 | 18900 | 18900 | 934 | 17 | 200 | 200 | C | CiC | X | C | XC40 | 1710 | C | 17 | X | EB | LND | 1710 |  |  |  |  |  |  |  |  | MO11 |  |  |  |  |  |  | x |  | C9-1 |  |  |  |  | OD 33>21 | Comp | MTA |  |  |  |  |  |
| XC40171022 |  | CA17 ExtrBldgFl1 - Erection Precast Beams <12m finished | milestone | 0d | 2011-05-01 A | 2011-05-01 A | XC20171005, XC40171015 | 100% |  |  |  |  |  |  | TB26 - 3 - Construction Normal 7days * CA17 |  |  |  |  | CA17 - critical - CW5 | XC40171022 | 0 | 0 | 934 | 17 | 200 | 200 | C | CiC | X | C | XC40 | 1710 | C | 17 | X | EB | LND | 1710 |  |  |  |  |  |  |  |  | MO11 |  |  |  |  |  |  |  |  |  |  |  | x |  |  |  |  |  |  |  |  |  |
| XC20171010 |  | CA17 ExtrBldgFl1 - Concrete Works Extruder Fdtn |  | 107d | 2011-05-19 A | 2011-08-26 A | XC40171020 FS+4d, EC28171010 (other project) FS+10d, XC20171005 | 100% |  | 2011-05-19 | 2011-09-03 |  |  |  | TB26 - 3 - Construction Normal 7days * CA17 | Concrete works [1480 cbm]; Concrete works [44400 h] | 20,324.92 |  | 44400,00 |  | XC20171010 | 44400 | 22740 | 934 | 17 | 200 | 200 | C | MO03 | X | C | XC20 | 1710 | C | 17 | X | EB | LND | 1710 |  |  |  |  |  |  |  |  | MO11 |  |  |  |  |  |  |  |  | C9-1 |  |  |  | 27.8. |  | x |  | UDF_G4 | x |  |  |  |
| XC40171026 |  | CA17 ExtrBldgFl1 - Concrete Works Ceiling +12m finished | milestone | 0d | 2011-05-20 A | 2011-05-20 A | XC40171020 FF | 100% |  |  |  |  |  |  | TB26 - 3 - Construction Normal 7days * CA17 |  |  |  |  | CA17 - critical - CW5 | XC40171026 | 0 | 0 | 934 | 17 | 200 | 200 | C | CiC | X | C | XC40 | 1710 | C | 17 | X | EB | LND | 1710 |  |  |  |  |  |  |  |  | MO11 |  |  |  |  |  |  |  |  |  |  |  |  |  |  |  |  |  |  | MTA |  |  |
| XC40171013 |  | CA17 ExtrBldgFl1 - Concrete Works Walls <12m (G-H/1-6) |  | 131d | 2011-06-14 A | 2011-11-30 | XC40171012, XC40171020 |  | 88d | 2011-06-14 | 2011-10-22 | -154d | 0d |  | TB26 - 3 - Construct-winter 7days * | Concrete works [790 cbm]; Concrete works [23700 h] | 22,690 |  | 33000,00 | CA17 - critical - CW5 | XC40171013 | 23700 | 0 | 934 | 17 | 200 | 200 | C | MO04 | X | C | XC40 | 1710 | C | 17 | X | EB | LND | 1710 |  |  |  |  |  |  |  |  | MO11 |  |  |  |  |  |  | x |  | C9-1 |  |  | x | 27.8. |  | x |  | UDF_G4 | x |  |  |  |
| XC191710 |  | CA17 ExtrBldgFl1 - Backfill inside (after Extruder instal, HVAC ducts, overhead cr. inst. |  | 20.12d | 2011-10-17 | 2011-11-14 | XC911710 FF+10d, XC20171010, XC40171012 FF+10d |  |  |  |  | -106.88d | 0d | start on or after 2011-10-17 | TB26 - T - Construct-Winter-3 (Dec/Jan/Feb free) * | Backfill & Compaction [12500 cbm]; Backfill & Compaction [18750 h] | 1,125,000 |  | 18750,00 |  | XC191710 | 18750 | 0 | 934 | 17 | 200 | 200 | C | CiC | X | C | XC19 | 1710 | C | 17 | X | UG | LND | 1710 |  |  |  |  |  |  |  |  | MO11 |  |  |  |  |  |  |  |  |  |  |  |  |  |  |  |  |  |  |  | X |  |
| XC301710 |  | CA17 ExtrBldgFl1 - UG Installation inside |  | 45d | 2011-10-18 | 2011-12-02 | EC301710 (other project) FS+20d, P3R02S1 (other project), P3R02AS1 (other project), ER441710 (other project), XC40171010, XC300C00, XC20171010 FS-10d, P3R02BS (other project), XC310C00, XC191710 SS |  |  |  |  | -125d | 0d | start on or after 2011-09-20 | TB26 - 3 - Construction Normal 7days * CA17 |  |  |  | 300m |  | XC301710 | 0 | 0 | 934 | 17 | 200 | 200 | C | CiC | X | C | XC30 | 1710 | C | 17 | X | UG | LND | 1710 |  |  |  |  |  |  |  |  |  |  |  |  |  |  |  |  |  |  |  |  |  | 27.8. |  |  |  |  |  |  |  | 1 |
| XC20171015 |  | CA17 ExtrBldgFl1 - Concrete Works Small Fdtns |  | 30d | 2011-11-15 | 2011-12-14 | XC191710 |  |  |  |  | -87d | 0d |  | TB26 - 3 - Construction Normal 7days * CA17 |  |  |  |  |  | XC20171015 | 0 | 0 | 934 | 17 | 200 | 200 | C | MO03 | X | C | XC20 | 1710 | C | 17 | X | EB | LND | 1710 |  |  |  |  |  |  |  |  | MO11 |  |  |  |  |  |  |  |  |  |  |  |  |  |  |  |  |  |  |  |  |  |
| XC501710 |  | CA17 ExtrBldgFl1 - Finishing Works Rooms (incl. Sanitary) |  | 120d | 2011-11-15 | 2012-03-22 | XC191710 SS+20d, XC510C00 FS+15d, IMS-C-000080 FF, EC501710 (other project) FS+20d, XC001710 FF, P3S09S (other project) FF, XC40171020, P3S06S (other project) FF+20d |  |  |  |  | -92d | 0d |  | TB26 - 3 - Construction Normal 7days * CA17 | Finishing Works - Extrusion Building CA17 [33592 mhr]; Finishing Works - Extrusion building CA17 [33592 h] | 3,359,200 |  | 33592,00 |  | XC501710 | 33592 | 0 | 934 | 17 | 200 | 200 | C | CiC | X | C | XC50 | 1710 | C | 17 | X | EB | LND | 1710 |  |  |  |  |  |  |  |  |  |  |  |  |  |  |  |  |  |  |  |  |  |  |  |  |  |  |  | XC50 |  | 1 |
| XC50171005 |  | CA17 ExtrBldgFl1 - Finishing Works Rooms E&I |  | 60d | 2011-11-15 | 2012-01-20 | XC601710 SF+20d, XC510C00 FS+15d, XC40171020, IMS-C-000080 FF, EC501710 (other project) FS+20d, XC191710 SS+20d |  |  |  |  | -92d | 0d |  | TB26 - 3 - Construction Normal 7days * CA17 |  |  |  |  |  | XC50171005 | 0 | 0 | 934 | 17 | 200 | 200 | C | CiC | X | C | XC50 | 1710 | C | 17 | X | EB | LND | 1710 |  |  |  |  |  |  |  |  |  |  |  |  |  |  |  |  |  |  |  |  |  |  |  |  |  |  |  |  |  | 1 |
| XC501710_1 |  | CA17 ExtrBldgFl1 - Plastering and Painting Rooms (incl. Sanitary) |  | 20d | 2011-11-15 | 2011-12-04 | XC501710 SS |  |  |  |  | -92d | 0d |  | TB26 - 3 - Construction Normal 7days * CA17 |  |  |  | 33592,00 |  | XC501710 | 33592 | 0 | 934 | 17 | 200 | 200 | C | CiC | X | C | XC50 | 1710 | C | 17 | X | EB | LND | 1710 |  |  |  |  |  |  |  |  |  |  |  |  |  |  |  |  |  |  |  |  |  |  |  |  |  |  |  |  |  | 1 |
| XC601710 |  | CA17 ExtrBldgFl1 - Paving inside |  | 25d | 2011-11-18 | 2011-12-12 | XC191710 FF+10d, XC301710 FF+10d, EC601710 (other project) FS+20d, XC191710 SS+10d |  |  |  |  | -125d | 0d |  | TB26 - 3 - Construction Normal 7days * CA17 | Concrete paved areas & concrete Roads [3800 sqm]; Concrete paved areas & concrete roads [14250 h] | 12,837.96 |  | 14250,00 |  | XC601710 | 14250 | 0 | 934 | 17 | 200 | 200 | C | CiC | X | C | XC60 | 1710 | C | 17 | X | PV | LND | 1710 |  |  |  |  |  |  |  |  | MO11 |  |  |  |  |  |  |  |  |  |  |  |  |  |  |  |  |  |  |  |  | 1 |
| XC50171010 |  | CA17 ExtrBldgFl1 - Finishing Works Rooms E&I finished | milestone | 0d | 2012-01-20 | 2012-01-20 | XC50171005 FF |  |  |  |  | -92d | 0d |  | TB26 - 3 - Construction Normal 7days * CA17 |  |  |  |  |  | XC50171010 | 0 | 0 | 934 | 17 | 200 | 200 | C | CiC | X | C | XC50 | 1710 | C | 17 | X | EB | LND | 1710 |  |  |  |  |  |  |  |  |  |  |  |  |  |  |  |  |  |  |  |  |  |  |  |  |  |  |  |  |  | 1 |

Notes:
- XE911709: UDF_PREDECESSOR: XN30, DEL XE40, DEL XE80, DEL XJ40, Civil 100%, Equipment 100%
- XE401708: Current Status: 20110705 (O.Siegel): keine / Verknьpfung zu Piping, da auf unterschiedlichen Ebenen gearbeitet wird, so dass / auch keine Behinderungen/ Beschдdigungen zu erwarten sind. / UDF_PREDECESSOR: XN30, Piping 50%
- XE801708: UDF_PREDECESSOR: XR40, Piping 50% pressure tests
- XE501708: UDF_PREDECESSOR: XE40, XE50, DEL XE34
- XJ421708: UDF_PREDECESSOR: XE40, XJ32, Equipment 100%, Piping 50%
- XJ521708: UDF_PREDECESSOR: XE40, XJ32, XJ52
- XW501708: P3 Activity Log Info: Clarification Surface / Protection during Prefab
- XC151710: P3 Activity Log Info: 268 bored piles
- XC40171010: Current Status: 12.01.2011 (Oxana): Endtermin auf den 31.01.2011 / verschoben, nach Absprache mit OAO "Moststroy" (am 11.01.2011)- Ressourcen / entsprechend CPMR-Werte angepasst (27%)
- XC40171012: Current Status: 12.01.2011 (Oxana): Endtermin hat sich neuberechnet (in / Abhдngigkeit von XC40171012).
- XC40171015: Current Status: 19.02.2011 (O.Siegel): auf dem Civil-meeting am 18-Feb-11 / wurde entschieden, dass MO11 ab dem 21-Feb-11 mit der Montage der vorhandenen 4 / Beams beginnt.
- XC40171013: Current Status: 12.01.2011 (Oxana): Endtermin hat sich neuberechnet (in / Abhдngigkeit von XC40171012).
- XC191710: Current Status: 20110906 (O.Siegel): Backfill inside / wird begonnen nach der insatalltion der Extruder, der groЯen HVAC-ducts, des / overhead cranes / . / 28.04.2011 (O.Siegel): Backfill inside und outside mьssen gleichzeitig / beginnen und parallel verlaufen. Sonst gibt es keinen Zugang in / die CA17
- XC301710: P3 Activity Log Info: Clarification Prefab Catch Basins/pulling / pits

| ID | WBS | Activity | Type | Duration | Start | Finish | Predecessors | Complete | Total float | Free float | Constraint | Calendar | Resources | Cost | Actual cost | TB26 Ressource Budget | UDF_SAVE ACT ID | UDF_CHECK BASELINE | UDF_BUDGETED LABOR UNIT | UDF_ACTUAL LABOR UNIT | Department | Type of Work | Constr. Area | PMT-Area | PMT-Schedule Org | PMT-Phase | PMT-Respons. | Zeigen/n. Zeigen | WBS Phase | WBS Discipline | WBS Type of Work | WBS Objects | Russia WBS Discipline (Russia) | Russia Construction Area | Russia WBS Phase | IMS | UPT | Russia WBS Objects | UDF_Text4 | UDF_CONTRACT START DATE | UDF_CONTRACT FINISH DATE | UDF_CONTRACT ITEM | UDF_SELECT UPDATE PROGRESS | Inquiry/Order No | 4 week lookahead | Subcontractor | UDF_SELECT | Comments | TB26 Semantics | UDF_L3 START DATE | UDF_L3 FINISH DATE | UDF_CONTRACT DATE PENALIZED | UDF_Weight (ton) | WEIGHT | UDF_LEVEL | UDF_PO No | UDF_TAG No | UDF_Object No | UDF_DELIVERY DATE PO | UDF_DELIVERY DATE DISPATCH PLANNED | UDF_DELIVERY DATE TO SITE PLANNED | UDF_DELIVERY DATE SITE NEED DATE | UDF_PACKAGE | UDF_SUPPLIER | UDF_Vendor Representatives | EQPT-Group PP | POSITION |
| --- | --- | --- | --- | --- | --- | --- | --- | --- | --- | --- | --- | --- | --- | --- | --- | --- | --- | --- | --- | --- | --- | --- | --- | --- | --- | --- | --- | --- | --- | --- | --- | --- | --- | --- | --- | --- | --- | --- | --- | --- | --- | --- | --- | --- | --- | --- | --- | --- | --- | --- | --- | --- | --- | --- | --- | --- | --- | --- | --- | --- | --- | --- | --- | --- | --- | --- | --- |
|  | N | **Structural Steel** |  |  | 2011-02-15 | 2012-03-20 |  |  |  |  |  |  |  |  |  |  |  |  |  |  |  |  |  |  |  |  |  |  |  |  |  |  |  |  |  |  |  |  |  |  |  |  |  |  |  |  |  |  |  |  |  |  |  |  |  |  |  |  |  |  |  |  |  |  |  |  |  |
| XN721701 |  | CA17 ExtrBldgFl1 SK1701- KMD Assy Drawings Monorails | milestone | 0d | 2011-02-15 A | 2011-02-15 A |  | 100% |  |  | finish on 2011-02-15 | TB26 - V - Construct-Winter partly * |  |  |  | 22t | XN721701 | x | 0 | 0 | 934 | XNK | 17 | 200 | 200 | C | LND | KMD | X | N | XN05 | 1710 | N | 17 | X | SS | LND | 1710 |  |  |  |  |  |  |  |  |  |  |  |  |  |  |  |  |  |  |  |  |  |  |  |  |  |  |  |  |  |
| XN741701 |  | CA17 ExtrBldgFl1 SK1701- KMD Assy Drawings Platf. extrus. floor | milestone | 0d | 2011-02-15 A | 2011-02-15 A |  | 100% |  |  | finish on 2011-02-15 | TB26 - V - Construct-Winter partly * |  |  |  | 22t | XN741701 | x | 0 | 0 | 934 | XNK | 17 | 200 | 200 | C | LND | KMD | X | N | XN05 | 1710 | N | 17 | X | SS | LND | 1710 |  |  |  |  |  |  |  |  |  |  |  |  |  |  |  |  |  |  |  |  |  |  |  |  |  |  |  |  |  |
| XN731701 |  | CA17 ExtrBldgFl1 SK1701- Steel Deliveries Monorails | milestone | 0d | 2011-02-24 A | 2011-02-24 A |  | 100% |  |  | finish on 2011-02-24 | TB26 - 3 - Construction Normal 7days * CA17 |  |  |  | 22t | XN731701 |  | 0 | 0 | 934 | XNK | 17 | 200 | 200 | C | LND | SD | X | N | XN06 | 1710 | N | 17 | X | SS | LND | 1710 |  |  |  |  |  |  |  |  |  |  |  |  |  |  |  |  |  |  |  |  |  |  |  |  |  |  |  |  |  |
| XN751701 |  | CA17 ExtrBldgFl1 SK1701- Steel Deliveries Platf. extrus. floor | milestone | 0d | 2011-02-24 A | 2011-02-24 A |  | 100% |  |  | finish on 2011-02-24 | TB26 - 3 - Construction Normal 7days * CA17 |  |  |  | 22t | XN751701 |  | 0 | 0 | 934 | XNK | 17 | 200 | 200 | C | LND | SD | X | N | XN06 | 1710 | N | 17 | X | SS | LND | 1710 |  |  |  |  |  |  |  |  |  |  |  |  |  |  |  |  |  |  |  |  |  |  |  |  |  |  |  |  |  |
| XN761710 |  | CA17 SK1710 - KMD Assy Drawings | milestone | 0d | 2011-04-15 A | 2011-04-15 A |  | 100% |  |  | finish on 2011-04-15 | TB26 - 3 - Construction Normal 7days * CA17 |  |  |  | 22t | XN761710 | x | 0 | 0 | 934 | XNK | 17 | 200 | 200 | C | LND | KMD | X | N | XN05 | 1710 | N | 17 | X | SS | LND | 1700 |  |  |  |  |  |  |  |  |  |  |  |  |  |  |  |  |  |  |  |  |  |  |  |  |  |  |  |  |  |
| XN201710 |  | CA17 ExtrBldgFl1 SK1701- Erec Prim Steel+M.Sheets <12m |  | 45d | 2011-04-25 A | 2011-06-10 A | XC20171010, P3N012D (other project) FS+5d, P3N01S (other project) FF, P3N02NN (other project), XC40171015 FF | 100% |  |  |  | TB26 - 3 - Construction Normal 7days * CA17 | Piperacks, Main Structures [37 t]; Piperacks, Main structures [1572.5 h] | 62,900 | 62,900 | 1572,50 | XN201710 |  | 1572,5 | 1572,5 | 934 | PU10 | 17 | 200 | 200 | C | LND | C9-1 | X | N | XN20 | 1711 | C | 17 | X | SS | LND | 1710 | CA17 - critical - CW5 | 2011-01-10 | 2011-01-20 | E-04-12 | x | 2DC8990 | x | ChSK |  |  |  |  |  |  |  |  |  |  |  |  |  |  |  |  |  |  |  |  |  |
| XN771710 |  | CA17 SK1710 - Steel Deliveries | milestone | 0d | 2011-05-01 A | 2011-05-01 A |  | 100% |  |  | finish on 2011-04-24 | TB26 - 3 - Construction Normal 7days * CA17 |  |  |  | 22t | XN771710 | x | 0 | 0 | 934 | XNK | 17 | 200 | 200 | C | LND | SD | X | N | XN06 | 1710 | N | 17 | X | SS | LND | 1700 |  |  |  |  |  |  |  |  |  |  |  |  |  |  |  |  |  |  |  |  |  |  |  |  |  |  |  |  |  |
| XC701710 |  | CA17 ExtrBldgFl1 SK1701 - Install Supports Ceiling <12m |  | 50d | 2011-11-25 | 2012-01-20 | XC191710 SS+10d, P3N02NN (other project), XN201704 SS |  | -27d | 0d |  | TB26 - 3 - Construction Normal 7days * CA17 | Piperacks, Main Structures [57 t]; Piperacks, Main structures [2422.5 h] |  |  | 2422,50 | XC701710 |  | 2422,5 | 0 | 934 | XNK | 17 | 200 | 200 | C | LND |  | X | C | XN70 | 1710 | N | 17 | X | SS | LND | 1710 |  |  |  |  |  |  |  | MO11 | MTA | Support fьr die Rohrleitungen unter der Decke |  |  |  |  |  |  |  |  |  |  |  |  |  |  |  |  |  |  |  |
| XN301710 |  | CA17 ExtrBldgFl1 SK1701 - Install Eqpt Platforms |  | 60d | 2011-12-13 | 2012-02-17 | P3N02ON (other project), XC20171015 FS-15d, P3N02NN (other project), XC601710, P3N02MN (other project) |  | -100d | 0d |  | TB26 - 3 - Construction Normal 7days * CA17 | Ladders & platforms [24 t]; Ladders & platforms [2400 h] | 1,123.41 |  | 2400,00 | XN301710 |  | 2400 | 0 | 934 | XNK | 17 | 200 | 200 | C | LND |  | X | N | XN30 | 1710 | N | 17 | X | SS | LND | 1710 |  |  |  |  |  | 2DC8480 |  | ChSK |  |  | t |  |  |  |  |  |  |  |  |  |  |  |  |  |  |  |  |  |  |
| XN401710 |  | CA17 ExtrBldgFl1 SK1701 - Install Railings,Ladders,etc. |  | 50d | 2012-01-19 | 2012-03-10 | XN301710 FF+20d, EC701710 (other project) FF |  | -100d | 0d |  | TB26 - 3 - Construction Normal 7days * CA17 | Ladders & platforms | 155.21 |  | 0,00 | XN401710 |  | 0 | 0 | 934 | XNK | 17 | 200 | 200 | C | LND |  | X | N | XN40 | 1710 | N | 17 | X | SS | LND | 1710 |  |  |  |  |  |  |  | ChSK |  |  |  |  |  |  |  |  |  |  |  |  |  |  |  |  |  |  |  |  |  |
| XN801710 |  | CA17 ExtrBldgFl1 SK1701 - Install Cladding |  | 30d | 2012-02-11 | 2012-03-13 | P3N02§N (other project), EN801711 (other project), XN201710 SS+10d, P3N03N (other project), XC40171020 FF |  | 31d | 0d | as late as possible | TB26 - 3 - Construction Normal 7days * CA17 | Cladding [1380 sqm]; Cladding [6900 h] | 2,266.04 |  | 6900,00 | XN801710 |  | 6900 | 0 | 934 | XNK | 17 | 200 | 200 | C | LND |  | X | N | XN80 | 1710 | N | 17 | X | SS | LND | 1710 |  |  |  |  |  |  |  | ChSK |  |  |  |  |  |  |  |  |  |  |  |  |  |  |  |  |  |  |  |  |  |
| XN601710 |  | CA17 ExtrBldgFl1 SK1701 - Install Gratings |  | 30d | 2012-02-18 | 2012-03-20 | EN641770 (other project), XN401710 FF+10d, IMS-C-000150 FF, EN641704 (other project), EN671705 (other project), EN641705 (other project), PN691710 (other project), EN671704 (other project) |  | -100d | 25d |  | TB26 - 3 - Construction Normal 7days * CA17 | Grating [300 sqm]; Grating [1125 h] | 8,639.94 |  | 1125,00 | XN601710 |  | 1125 | 0 | 934 | XNK | 17 | 200 | 200 | C | LND |  | X | N | XN60 | 1710 | N | 17 | X | SS | LND | 1710 |  |  |  |  |  |  |  | ChSK |  |  |  |  |  |  |  |  |  |  |  |  |  |  |  |  |  |  |  |  |  |
|  | H | **HVAC** |  |  | 2011-12-05 | 2012-06-02 |  |  |  |  |  |  |  |  |  |  |  |  |  |  |  |  |  |  |  |  |  |  |  |  |  |  |  |  |  |  |  |  |  |  |  |  |  |  |  |  |  |  |  |  |  |  |  |  |  |  |  |  |  |  |  |  |  |  |  |  |  |
| XH00171005 |  | CA17 ExtrBldgFl1 - Installation HVAC |  | 90d | 2011-12-05 | 2012-03-12 | P3H01SI (other project), XC501710 SS, XH000000 FF, XC40171020, XC50171005 SS, EH30171005 (other project), XC501710_1 |  | -92d | 0d |  | TB26 - 3 - Construction Normal 7days * CA17 | HVAC - Extrusion Building CA17 [10283 mhr]; HVAC - Extrusion building CA17 [10283 h] |  |  | 10283,00 | XH00171005 |  | 10283 | 0 | 934 | XBB | 17 | 200 | 200 | C | LND |  | X | H | XH00 | 1700 | H | 17 | X | hvac | LND | 1710 |  | 2011-05-10 | 2011-08-25 |  |  |  |  | ARMO | REL XC50 |  |  | 2011-05-14 | 2011-08-07 |  |  |  |  |  |  |  |  |  |  |  |  |  |  |  |  |
| XH00171006 |  | CA17 ExtrBldgFl1 - Installation HVAC E&I Rooms |  | 35d | 2012-01-21 | 2012-02-25 | XH00171005 SS, XC50171010 |  | -92d | 0d |  | TB26 - 3 - Construction Normal 7days * CA17 |  |  |  |  | XH00171006 |  | 0 | 0 | 934 | XBB | 17 | 200 | 200 | C | LND |  | X | H | XH00 | 1710 | H | 17 | X | hvac | LND | 1710 |  | 2011-05-10 | 2011-06-20 |  |  |  |  | ARMO |  |  |  | 2011-06-22 | 2011-07-20 |  |  |  |  |  |  |  |  |  |  |  |  |  |  |  |  |
| XH00171007 |  | CA17 ExtrBldgFl1 - Installation HVAC E&I Rooms finished | milestone | 0d | 2012-02-25 | 2012-02-25 | XH00171006 FF |  | -92d | 0d |  | TB26 - 3 - Construction Normal 7days * CA17 |  |  |  |  | XH00171007 |  | 0 | 0 | 934 | XBB | 17 | 200 | 200 | C | LND |  | X | H | XH00 | 1710 | H | 17 | X | hvac | LND | 1710 |  | 2011-06-20 | 2011-06-20 | CM05 |  |  |  | ARMO |  |  |  | 2011-07-20 | 2011-07-20 | P |  |  |  |  |  |  |  |  |  |  |  |  |  |  |  |
| XH00171008 |  | CA17 ExtrBldgFl1 - Installation HVAC finished | milestone | 0d | 2012-03-12 | 2012-03-12 | XH00171005 FF |  | 162d | 162.5d |  | TB26 - 3 - Construction Normal 7days * CA17 |  |  |  |  | XH00171008 |  | 0 | 0 | 934 | XBB | 17 | 200 | 200 | C | LND |  | X | H | XH00 | 1710 | H | 17 | X | hvac | LND | 1710 |  | 2011-08-25 | 2011-08-25 | CM06 |  |  |  | ARMO |  |  |  | 2011-08-07 | 2011-08-07 |  |  |  |  |  |  |  |  |  |  |  |  |  |  |  |  |
| XH00171010 |  | CA17 ExtrBldgFl1 - Testing/Commissiong HVAC (Start w. temp. Power) |  | 80d | 2012-03-13 | 2012-06-02 | X0300060, XH000C10, XH00171005, X0300008 FS+20d, X0300080 |  | 82d | 0d |  | TB26 - 3 - Construction Normal 7days * CA17 |  |  |  |  | XH00171010 |  | 0 | 0 | 934 | XBB | 17 | 200 | 200 | C | LND |  | X | H | XH20 | 1710 | H | 17 | X | hvac | LND | 1710 |  | 2011-08-20 | 2011-11-01 |  |  |  |  | ARMO |  |  |  | 2011-08-07 | 2011-10-11 |  |  |  |  |  |  |  |  |  |  |  |  |  |  |  |  |
| XH00171011 |  | CA17 ExtrBldgFl1 - HVAC ready for Heating | milestone | 0d | 2012-03-23 | 2012-03-23 | XH00171010 SS+10d |  | 369.5d | 152.5d |  | TB26 - 3 - Construction Normal 7days * CA17 |  |  |  |  | XH00171011 |  | 0 | 0 | 934 | XBB | 17 | 200 | 200 | C | LND |  | X | H | XH00 | 1710 | H | 17 | X | hvac | LND | 1710 |  |  |  | CM06 |  |  |  | ARMO |  |  |  | 2011-08-17 | 2011-08-17 |  |  |  |  |  |  |  |  |  |  |  |  |  |  |  |  |
| XH00171015 |  | CA17 ExtrBldgFl1 - Testing/Commissiong HVAC finished | milestone | 0d | 2012-06-02 | 2012-06-02 | XH00171010 FF |  | 82d | 193.5d |  | TB26 - 3 - Construction Normal 7days * CA17 |  |  |  |  | XH00171015 |  | 0 | 0 | 934 | XBB | 17 | 200 | 200 | C | LND |  | X | H | XH20 | 1710 | H | 17 | X | hvac | LND | 1710 |  | 2011-11-01 | 2011-11-01 | CM07 |  |  |  | ARMO |  |  |  | 2011-10-11 | 2011-10-11 |  |  |  |  |  |  |  |  |  |  |  |  |  |  |  |  |
|  | U | **Package Units** |  |  | 2011-09-19 | 2012-02-29 |  |  |  |  |  |  |  |  |  |  |  |  |  |  |  |  |  |  |  |  |  |  |  |  |  |  |  |  |  |  |  |  |  |  |  |  |  |  |  |  |  |  |  |  |  |  |  |  |  |  |  |  |  |  |  |  |  |  |  |  |  |
| EX-21401 |  | Extruder Package Line 1 |  | 50d | 2011-09-19 | 2011-11-16 | X000171001 FF, XC20171010, X000171001 SS, P3M01SA (other project) |  | -16d | 0d | start on or after 2011-09-19 |  | Extruder [521 mhr]; Extruder [521 h] | 52,100 |  | 555,00 | EX-21401 |  | 521 | 0 |  |  | 17 |  |  |  |  | EQ | X | U |  | 1710 |  |  |  |  |  |  |  |  |  |  |  |  |  |  |  |  |  |  |  |  | 55,5 | 55500 | concrete +0.465 | 2 DC 8480 / 7 | EX-21401 | SK1710 | 2011-01-14 | 2011-01-15 | 2011-03-15 | 2011-03-25 | M01 EXTRUDER (EX-21-/22401) | Japan Steel Works | 036 | EX-21401 |  |
| X000171001 |  | Extruder Package Line 1 - ALL | level of effort | 86d | 2011-09-19 | 2011-12-28 |  |  | -17d | 0d |  |  | Extruder |  |  | 0,00 | X000171001 | x | 0 | 0 |  |  | 17 |  |  |  |  | EQ | X | U |  | 1710 |  |  |  |  |  |  |  |  |  |  |  |  |  |  |  |  |  |  |  |  |  | 2100 |  | 2 DC 8480 / 7 | EX-21401-MI02 | SK1710 | 2011-01-14 | 2011-01-15 | 2011-03-15 | 2011-03-25 | M01 EXTRUDER (EX-21-/22401) | Japan Steel Works |  | EX-21401 |  |
| EX-22401 |  | Extruder Package Line 2 |  | 50d | 2011-10-13 | 2011-12-10 | XC20171010, EX-21401 SS+21d, X000171002 FF, P3M01SA (other project), X000171002 SS |  | -12d | 0d |  |  | Extruder [521 mhr]; Extruder [521 h] | 52,100 |  | 555,00 | EX-22401 |  | 521 | 0 |  |  | 17 |  |  |  |  | EQ | X | U |  | 1710 |  |  |  |  |  |  |  |  |  |  |  |  |  |  |  |  |  |  |  |  | 55,5 | 55500 | concrete +0.465 | 2 DC 8480 / 7 | EX-22401 | SK1710 | 2011-01-14 | 2011-01-15 | 2011-03-15 | 2011-03-25 | M01 EXTRUDER (EX-21-/22401) | Japan Steel Works | 036 | EX-22402 |  |
| X000171002 |  | Extruder Package Line 2 - ALL | level of effort | 65d | 2011-10-13 | 2011-12-28 |  |  | -17d | 0d |  |  | Extruder |  |  | 0,00 | X000171002 | x | 0 | 0 |  |  | 17 |  |  |  |  | EQ | X | U |  | 1710 |  |  |  |  |  |  |  |  |  |  |  |  |  |  |  |  |  |  |  |  |  | 2100 |  | 2 DC 8480 / 7 | EX-21401-MI02 | SK1710 | 2011-01-14 | 2011-01-15 | 2011-03-15 | 2011-03-25 | M01 EXTRUDER (EX-21-/22401) | Japan Steel Works |  | EX-22402 |  |
| EX-21401-G01 |  | EXTRUDER GEAR REDUCER |  | 11d | 2011-10-19 | 2011-10-31 | P3M14S2 (other project), X000171001 SS, P3M01SA (other project), EX-21401 SS, X000171001 FF |  | 1d | 0d |  |  | Extruder [480 mhr]; Extruder [480 h] | 48,000 |  | 480,00 | EX-21401-G01 |  | 480 | 0 |  |  | 17 |  |  |  |  | EQ | X | U |  | 1710 |  |  |  |  |  |  |  |  |  |  |  |  |  |  |  |  |  |  |  |  | 48 | 48000 | concrete +0.300 | 2 DC 8480 / 7 | EX-21401-G01 | SK1710 | 2011-01-14 | 2011-01-15 | 2011-03-15 | 2011-03-25 | M01 EXTRUDER (EX-21-/22401) | Japan Steel Works |  | EX-21401 |  |
| EX-22401-G01 |  | Extruder GEAR REDUCER |  | 20d | 2011-10-19 | 2011-11-11 | X000171002 FF, X000171002 SS, EX-22401 SS, P3M01SA (other project), P3M14S2 (other project) |  | -8d | 0d |  |  | Extruder [480 mhr]; Extruder [480 h] | 48,000 |  | 480,00 | EX-22401-G01 |  | 480 | 0 |  |  | 17 |  |  |  |  | EQ | X | U |  | 1710 |  |  |  |  |  |  |  |  |  |  |  |  |  |  |  |  |  |  |  |  | 33 | 48000 | concrete +0.300 |  | EX-22401-G01 | SK1710 |  |  |  |  | M01 EXTRUDER (EX-21-/22401) |  |  | EX-22402 |  |
| EX-21401-M01 |  | EXTRUDER MOTOR |  | 21d | 2011-10-26 | 2011-11-19 | P3M14S2 (other project), EX-21401 SS, EX-21401-G01 SS+6d, P3M01SA (other project), X000171001 FF, X000171001 SS |  | 1d | 0d |  |  | Extruder [330 mhr]; Extruder [330 h] | 33,000 |  | 330,00 | EX-21401-M01 |  | 330 | 0 |  |  | 17 |  |  |  |  | EQ | X | U |  | 1710 |  |  |  |  |  |  |  |  |  |  |  |  |  |  |  |  |  |  |  |  | 33 | 33000 | concrete +0.650 | 2 DC 8480 / 7 | EX-21401-M01 | SK1710 | 2011-01-14 | 2011-01-15 | 2011-03-15 | 2011-03-25 | M01 EXTRUDER (EX-21-/22401) | Japan Steel Works |  | EX-21401 |  |
| EX-22401-M01 |  | EXTRUDER MOTOR |  | 25d | 2011-10-26 | 2011-11-24 | P3M14S2 (other project), EX-22401 SS, EX-22401-G01 SS+6d, X000171002 FF, P3M01SA (other project), X000171002 SS |  | -8d | 0d |  |  | Extruder [330 mhr]; Extruder [330 h] | 33,000 |  | 330,00 | EX-22401-M01 |  | 330 | 0 |  |  | 17 |  |  |  |  | EQ | X | U |  | 1710 |  |  |  |  |  |  |  |  |  |  |  |  |  |  |  |  |  |  |  |  | 48 | 33000 | concrete +0.650 | 2 DC 8480 / 7 | EX-22401-M01 | SK1710 | 2011-01-14 | 2011-01-15 | 2011-03-15 | 2011-03-25 | M01 EXTRUDER (EX-21-/22401) | Japan Steel Works |  | EX-22402 |  |
| EX-21401-PE01 |  | UNDERWATER PELLETIZER |  | 2d | 2011-11-01 | 2011-11-02 | X000171001 FF, EX-21401-G01, X000171001 SS |  | 30d | 137d |  |  | Extruder [200 mhr]; Extruder [200 h] | 20,000 |  | 200,00 | EX-21401-PE01 |  | 200 | 0 |  |  | 17 |  |  |  |  | EQ | X | U |  | 1710 |  |  |  |  |  |  |  |  |  |  |  |  |  |  |  |  |  |  |  |  | 20 | 20000 | at rail +0.150 | 2 DC 8480 / 7 | EX-21401-PE01 | SK1710 | 2011-01-14 | 2011-01-15 | 2011-03-15 | 2011-03-25 | M01 EXTRUDER (EX-21-/22401) | Japan Steel Works |  | EX-21401 |  |
| EX-21401-SE01 |  | SCREEN PACK CHANGER |  | 2d | 2011-11-02 | 2011-11-03 | X000171001 SS, EX-21401-M01 SS+6d, X000171001 FF |  | 29d | 136d |  |  | Extruder [120 mhr]; Extruder [120 h] | 12,000 |  | 120,00 | EX-21401-SE01 |  | 120 | 0 |  |  | 17 |  |  |  |  | EQ | X | U |  | 1710 |  |  |  |  |  |  |  |  |  |  |  |  |  |  |  |  |  |  |  |  | 12 | 12000 | concrete +0.300 | 2 DC 8480 / 7 | EX-21401-SE01 | SK1710 | 2011-01-14 | 2011-01-15 | 2011-03-15 | 2011-03-25 | M01 EXTRUDER (EX-21-/22401) | Japan Steel Works |  | EX-21401 |  |
| EX-22401-SE01 |  | SCREEN PACK CHANGER |  | 8d | 2011-11-02 | 2011-11-11 | X000171002 FF, EX-22401-M01 SS+6d, X000171002 SS |  | 23d | 130d |  |  | Extruder [120 mhr]; Extruder [120 h] | 12,000 |  | 120,00 | EX-22401-SE01 |  | 120 | 0 |  |  | 17 |  |  |  |  | EQ | X | U |  | 1710 |  |  |  |  |  |  |  |  |  |  |  |  |  |  |  |  |  |  |  |  | 12 | 12000 | concrete +0.300 | 2 DC 8480 / 7 | EX-22401-SE01 | SK1710 | 2011-01-14 | 2011-01-15 | 2011-03-15 | 2011-03-25 | M01 EXTRUDER (EX-21-/22401) | Japan Steel Works |  | EX-22402 |  |
| EX-22401-PE01 |  | UNDERWATER PELLETIZER |  | 10d | 2011-11-12 | 2011-11-23 | X000171002 FF, EX-22401-G01, X000171002 SS |  | 13d | 120d |  |  | Extruder [200 mhr]; Extruder [200 h] | 20,000 |  | 200,00 | EX-22401-PE01 |  | 200 | 0 |  |  | 17 |  |  |  |  | EQ | X | U |  | 1710 |  |  |  |  |  |  |  |  |  |  |  |  |  |  |  |  |  |  |  |  | 20 | 20000 | at rail +0.150 | 2 DC 8480 / 7 | EX-22401-PE01 | SK1710 | 2011-01-14 | 2011-01-15 | 2011-03-15 | 2011-03-25 | M01 EXTRUDER (EX-21-/22401) | Japan Steel Works |  | EX-22402 |  |
| EX-21401-MI01 |  | HOT OIL UNIT |  | 5d | 2011-11-21 | 2011-11-25 | P3M01SA (other project), EX-21401-M01, X000171001 FF, X000171001 SS |  | 1d | 0d |  |  | Extruder [60 mhr]; Extruder [60 h] | 6,000 |  | 60,00 | EX-21401-MI01 |  | 60 | 0 |  |  | 17 |  |  |  |  | EQ | X | U |  | 1710 |  |  |  |  |  |  |  |  |  |  |  |  |  |  |  |  |  |  |  |  | 6 | 6000 | concrete +0.300 | 2 DC 8480 / 7 | EX-21401-MI01 | SK1710 | 2011-01-14 | 2011-01-15 | 2011-03-15 | 2011-03-25 | M01 EXTRUDER (EX-21-/22401) | Japan Steel Works |  | EX-21401 |  |
| EX-21401-MI03 |  | LUBE OIL UNIT for GEAR REDUCTOR |  | 2d | 2011-11-21 | 2011-11-22 | EX-21401-M01, P3M14S2 (other project), X000171001 SS, X000171001 FF |  | 12d | 0d |  |  | Extruder [50 mhr]; Extruder [50 h] | 5,000 |  | 50,00 | EX-21401-MI03 |  | 50 | 0 |  |  | 17 |  |  |  |  | EQ | X | U |  | 1710 |  |  |  |  |  |  |  |  |  |  |  |  |  |  |  |  |  |  |  |  | 5 | 2100 | concrete +0.300 | 2 DC 8480 / 7 | EX-21401-MI02 | SK1710 | 2011-01-14 | 2011-01-15 | 2011-03-15 | 2011-03-25 | M01 EXTRUDER (EX-21-/22401) | Japan Steel Works |  | EX-21401 |  |
| EX-21401-MI04 |  | LUBE OIL UNIT for EXTRUDER MOTOR |  | 2d | 2011-11-23 | 2011-11-24 | EX-21401-MI03, X000171001 SS, X000171001 FF, P3M14S2 (other project) |  | 12d | 119d |  |  | Extruder [8 mhr]; Extruder [8 h] | 800 |  | 8,00 | EX-21401-MI04 |  | 8 | 0 |  |  | 17 |  |  |  |  | EQ | X | U |  | 1710 |  |  |  |  |  |  |  |  |  |  |  |  |  |  |  |  |  |  |  |  | 0,8 | 2100 | concrete +0.300 | 2 DC 8480 / 7 | EX-21401-MI02 | SK1710 | 2011-01-14 | 2011-01-15 | 2011-03-15 | 2011-03-25 | M01 EXTRUDER (EX-21-/22401) | Japan Steel Works |  | EX-21401 |  |
| EX-22401-MI01 |  | HOT OIL UNIT |  | 5d | 2011-11-25 | 2011-11-30 | X000171002 FF, X000171002 SS, EX-22401-M01 |  | -8d | 0d |  |  | Extruder [60 mhr]; Extruder [60 h] | 6,000 |  | 60,00 | EX-22401-MI01 |  | 60 | 0 |  |  | 17 |  |  |  |  | EQ | X | U |  | 1710 |  |  |  |  |  |  |  |  |  |  |  |  |  |  |  |  |  |  |  |  | 6 | 6000 | concrete +0.300 | 2 DC 8480 / 7 | EX-22401-MI01 | SK1710 | 2011-01-14 | 2011-01-15 | 2011-03-15 | 2011-03-25 | M01 EXTRUDER (EX-21-/22401) | Japan Steel Works |  | EX-22402 |  |
| EX-22401-MI03 |  | LUBE OIL UNIT for GEAR REDUCTOR |  | 2d | 2011-11-25 | 2011-11-26 | X000171002 SS, X000171002 FF, EX-22401-M01 |  | 8d | 0d |  |  | Extruder [5 mhr]; Extruder [5 h] | 500 |  | 5,00 | EX-22401-MI03 |  | 5 | 0 |  |  | 17 |  |  |  |  | EQ | X | U |  | 1710 |  |  |  |  |  |  |  |  |  |  |  |  |  |  |  |  |  |  |  |  | 5 | 2100 | concrete +0.300 | 2 DC 8480 / 7 | EX-21401-MI02 | SK1710 | 2011-01-14 | 2011-01-15 | 2011-03-15 | 2011-03-25 | M01 EXTRUDER (EX-21-/22401) | Japan Steel Works |  | EX-22402 |  |
| EX-21401-MI02 |  | CCW UNIT |  | 2d | 2011-11-26 | 2011-11-28 | X000171001 FF, P3M01SA (other project), X000171001 SS, EX-21401-MI01 |  | 9d | 116d |  |  | Extruder [21 mhr]; Extruder [21 h] | 2,100 |  | 21,00 | EX-21401-MI02 |  | 21 | 0 |  |  | 17 |  |  |  |  | EQ | X | U |  | 1710 |  |  |  |  |  |  |  |  |  |  |  |  |  |  |  |  |  |  |  |  | 2,1 | 2100 | concrete +0.300 | 2 DC 8480 / 7 | EX-21401-MI02 | SK1710 | 2011-01-14 | 2011-01-15 | 2011-03-15 | 2011-03-25 | M01 EXTRUDER (EX-21-/22401) | Japan Steel Works |  | EX-21401 |  |
| EX-22401-MI04 |  | LUBE OIL UNIT for EXTRUDER MOTOR |  | 2d | 2011-11-28 | 2011-11-29 | EX-22401-MI03, X000171002 SS, X000171002 FF |  | 8d | 115d |  |  | Extruder [8 mhr]; Extruder [8 h] | 800 |  | 8,00 | EX-22401-MI04 |  | 8 | 0 |  |  | 17 |  |  |  |  | EQ | X | U |  | 1710 |  |  |  |  |  |  |  |  |  |  |  |  |  |  |  |  |  |  |  |  | 0,8 | 2100 | concrete +0.300 | 2 DC 8480 / 7 | EX-21401-MI02 | SK1710 | 2011-01-14 | 2011-01-15 | 2011-03-15 | 2011-03-25 | M01 EXTRUDER (EX-21-/22401) | Japan Steel Works |  | EX-22402 |  |
| EX-22401-MI02 |  | CCW UNIT |  | 2d | 2011-12-01 | 2011-12-02 | EX-22401-MI01, X000171002 SS, X000171002 FF |  | 5d | 112d |  |  | Extruder [21 mhr]; Extruder [21 h] | 2,100 |  | 21,00 | EX-22401-MI02 |  | 21 | 0 |  |  | 17 |  |  |  |  | EQ | X | U |  | 1710 |  |  |  |  |  |  |  |  |  |  |  |  |  |  |  |  |  |  |  |  | 2,1 | 2100 | concrete +0.300 | 2 DC 8480 / 7 | EX-22401-MI02 | SK1710 | 2011-01-14 | 2011-01-15 | 2011-03-15 | 2011-03-25 | M01 EXTRUDER (EX-21-/22401) | Japan Steel Works |  | EX-22402 |  |
| EX-21401-MX01 |  | MIXER FEED CHUTE |  | 5d | 2011-12-23 | 2011-12-28 | P3M14S2 (other project), X000171001 SS, X000171001 FF, XN301710 SS+10d, P3M01SA (other project), EX-21401 |  | -17d | 90d |  |  | Extruder [12 mhr]; Extruder [12 h] | 1,200 |  | 12,00 | EX-21401-MX01 |  | 12 | 0 |  |  | 17 |  |  |  |  | EQ | X | U |  | 1710 |  |  |  |  |  |  |  |  |  |  |  |  |  |  |  |  |  |  |  |  | 1,2 | 2100 | on EX-21401 | 2 DC 8480 / 7 | EX-21401-MI02 | SK1710 | 2011-01-14 | 2011-01-15 | 2011-03-15 | 2011-03-25 | M01 EXTRUDER (EX-21-/22401) | Japan Steel Works |  | EX-21401 |  |
| EX-22401-MX01 |  | MIXER FEED CHUTE |  | 5d | 2011-12-23 | 2011-12-28 | XN301710 SS+10d, X000171002 SS, EX-22401, P3M01SA (other project), X000171002 FF |  | -17d | 90d |  |  | Extruder [12 mhr]; Extruder [12 h] | 1,200 |  | 12,00 | EX-22401-MX01 |  | 12 | 0 |  |  | 17 |  |  |  |  | EQ | X | U |  | 1710 |  |  |  |  |  |  |  |  |  |  |  |  |  |  |  |  |  |  |  |  | 1,2 | 2100 | on EX-21401 | 2 DC 8480 / 7 | EX-21401-MI02 | SK1710 | 2011-01-14 | 2011-01-15 | 2011-03-15 | 2011-03-25 | M01 EXTRUDER (EX-21-/22401) | Japan Steel Works |  | EX-22402 |  |
| E-22402A/B |  | PELLETIZER WATER COOLER |  | 10d | 2011-12-29 | 2012-01-17 | XC20171015, SE-22403A/B, P-22402A/B SS+5d, EX-22401 SS |  | -27.88d | 79.12d |  |  | Extruder [78 mhr]; Extruder [78 h] | 7,800 |  | 78,00 | E-22402A/B |  | 78 | 0 |  |  | 17 |  |  |  |  | EQ | X | U |  | 1710 |  |  |  |  |  |  |  |  |  |  |  |  |  |  |  |  |  |  |  |  | 3,9 | 3900 | concrete +0.300 |  | E-22402A/B | SK1710 |  |  |  |  | M01 EXTRUDER (EX-21-/22401) |  |  |  | a |
| E-21402A/B |  | PELLETIZER WATER COOLER |  | 10d | 2012-02-17 | 2012-02-29 | EX-21401 SS, P-21402A/B SS+5d, SE-21403A/B, XC20171015 |  | -64d | 43d |  |  | Extruder [78 mhr]; Extruder [78 h] | 7,800 |  | 78,00 | E-21402A/B |  | 78 | 0 |  |  | 17 |  |  |  |  | EQ | X | U |  | 1710 |  |  |  |  |  |  |  |  |  |  |  |  |  |  |  |  |  |  |  |  | 3,9 | 3900 | concrete +0.300 |  | E-21402A/B | SK1710 |  |  |  |  | M01 EXTRUDER (EX-21-/22401) |  |  |  | a |

Notes:
- XN731701: Scope: 09.02.2011: weight: 50 ton - Mrz 50 ton
- XN751701: Scope: 09.02.2011: weight: 35 ton - Mrz 35 ton
- XN201710: Current Status: 05.02.2011 (O. Siegel): bis Ende Jan 2011 wirden keine / Stahlarbeiten durchgefьhrt.
- XN771710: Scope: 09.02.2011: weight: 30 ton
- XH00171010: Current Status: 21.01.2011 - Siegel - Vorgдnger zur IBN HVAC / Condensat, LP-Dampf, Kьhlwasser von FF + 30 Tage Lag auf FS + 0 geдndert!

| ID | WBS | Activity | Type | Duration | Start | Finish | Predecessors | Total float | Free float | Constraint | Calendar | Resources | Cost | TB26 Ressource Budget | POSITION | WEIGHT | UDF_LEVEL | UDF_TAG No | UDF_Object No | UDF_DELIVERY DATE PO | UDF_DELIVERY DATE DISPATCH PLANNED | UDF_DELIVERY DATE TO SITE PLANNED | UDF_DELIVERY DATE SITE NEED DATE | UDF_SUPPLIER | UDF_SAVE ACT ID | UDF_BUDGETED LABOR UNIT | UDF_ACTUAL LABOR UNIT | Constr. Area | Zeigen/n. Zeigen | WBS Phase | WBS Discipline | WBS Objects | UDF_Weight (ton) | UDF_SELECT | UDF_CONTRACT START DATE | UDF_CONTRACT FINISH DATE | UDF_CONTRACT ITEM | UDF_CONTRACT DATE PENALIZED | UDF_PENALIZED START | UDF_PENALIZED FINISH | Department | Type of Work | Inquiry/Order No | PMT-Area | PMT-Schedule Org | PMT-Phase | PMT-Respons. | WBS Type of Work | Russia WBS Discipline (Russia) | Russia Construction Area | Russia WBS Phase | IMS | UPT | Russia WBS Objects | UDF_PO No | UDF_Vendor Representatives |
| --- | --- | --- | --- | --- | --- | --- | --- | --- | --- | --- | --- | --- | --- | --- | --- | --- | --- | --- | --- | --- | --- | --- | --- | --- | --- | --- | --- | --- | --- | --- | --- | --- | --- | --- | --- | --- | --- | --- | --- | --- | --- | --- | --- | --- | --- | --- | --- | --- | --- | --- | --- | --- | --- | --- | --- | --- |
|  | B | **Mechanical - Stationary Equipment** |  |  | 2011-12-12 | 2012-03-14 |  |  |  |  |  |  |  |  |  |  |  |  |  |  |  |  |  |  |  |  |  |  |  |  |  |  |  |  |  |  |  |  |  |  |  |  |  |  |  |  |  |  |  |  |  |  |  |  |  |  |
| K-22502 A/B |  | TRANSFER AIR COMPRESSOR |  | 10d | 2011-12-12 | 2011-12-23 | XC601710, XB00171005 SS, EX-22401 FS-20d, P3U10S2B (other project), XB00171005 FF, XC20171010 | -27.88d | 42.12d |  |  | Static Equipment < 10 tons; Static equipment < 10t |  | 0,00 | a | 2770 | concrete +0,00 | K-22502 A/B | SK1710 | 2010-10-02 | 2010-11-30 | 2011-02-10 | 2011-02-10 | Zeppelin | K-22502 A/B | 0 | 0 | 17 | EQ | X | B | 1710 |  |  |  |  |  |  |  |  |  |  |  |  |  |  |  |  |  |  |  |  |  |  |  |  |
| SE-22403A/B |  | FINES SEPARATOR |  | 10d | 2011-12-12 | 2011-12-23 | P3m01SD (other project), XC601710, P3M01SA (other project), XC20171010, EX-22401 FS-20d | -27.88d | 0d |  |  | Extruder [6 mhr]; Extruder [6 h] | 600 | 6,00 | a | 600 | structure +3.650 | SE-22403A/B | SK1710 |  |  |  |  |  | SE-22403A/B | 6 | 0 | 17 | EQ | X | U | 1710 | 0,6 |  |  |  |  |  |  |  |  |  |  |  |  |  |  |  |  |  |  |  |  |  |  |  |
| TK-22402 |  | PELLETIZER WATER TANK |  | 10d | 2011-12-12 | 2011-12-23 | EX-22401 FS-20d, P3m01SD (other project), XC20171010, P3M01SA (other project), XC601710 | -27.88d | 0d |  |  | Extruder [50 mhr]; Extruder [50 h] | 5,000 | 50,00 | a | 5000 | concrete +0.30 | TK-22402 | SK1710 |  |  |  |  |  | TK-22402 | 50 | 0 | 17 | EQ | X | U | 1710 | 5 |  |  |  |  |  |  |  |  |  |  |  |  |  |  |  |  |  |  |  |  |  |  |  |
| XB00171005 |  | CA17 ExtrBldgFl1 - Install Static Eqpt. | level of effort | 84d | 2011-12-13 | 2012-03-14 | F4730 FF | 85d | 0d |  | TB26 - 3 - Construction Normal 7days * CA17 | Static Equipment < 10 tons [10.51 t]; Static equipment < 10t [1050.9 h] | 42,036 | 1050,90 |  |  |  |  |  |  |  |  |  |  | XB00171005 | 1050,9 | 0 | 17 |  | X | B | 1710 |  | OMUS-1 | 2011-04-15 | 2011-09-30 | E-08-01-12 | P | 2011-12-30 | 2011-12-30 | 934 | XBB | 2DC8480 | 200 | 200 | C | LND | XB00 | B | 17 | X | EQ | LND | 1710 |  |  |
| V-21901 |  | CONDENSATE KO DRUM |  | 10d | 2011-12-23 | 2012-01-10 | XB00171005 SS, P3A02S6 (other project), XN301710 SS+10d, XC40171020 FS-10d, XB00171005 FF | -42d | 0d |  |  | Static Equipment < 10 tons [9.5 t]; Static equipment < 10t [950 h] | 38,000 | 950,00 | a | 9500 | structure +4.00 | V-21901 | SK1710 | 2010-12-31 | 2011-01-15 | 2011-01-30 | 2011-02-18 | Tambovskij Zavod | V-21901 | 950 | 0 | 17 | EQ | X | B | 1710 | 9,5 |  |  |  |  |  |  |  |  |  |  |  |  |  |  |  |  |  |  |  |  |  | 2 DC 9450 |  |
| MI-21402 |  | RECOVERED ADDITIVE / OFF-SPEC PALLET SCALE |  | 5d | 2012-01-11 | 2012-01-17 | XC20171015, EX-22401 FS-20d, XX-21701, XB00171005 SS, P3A13S4 (other project), EX-21401 FS-20d, XB00171005 FF | -27.88d | 79.12d |  |  | Static Equipment < 10 tons [0.3 t]; Static equipment < 10t [30 h] | 1,200 | 30,00 | a | 2770 | concrete +0,325 | MI-21402 | SK1710 | 2010-10-02 | 2010-11-30 | 2011-02-10 | 2011-02-10 | Zeppelin | MI-21402 | 30 | 0 | 17 | EQ | X | B | 1710 | 0,3 |  |  |  |  |  |  |  |  |  |  |  |  |  |  |  |  |  |  |  |  |  |  |  |
| K-21502 A/B |  | TRANSFER AIR BLOWER |  | 20d | 2012-01-18 | 2012-02-09 | XB00171005 SS, P3U10S1B (other project), EX-21401, XB00171005 FF | -58d | 0d | start on or after 2012-01-18 |  | Static Equipment < 10 tons [12.04 t]; Static equipment < 10t [1204 h] | 48,152 | 1204,00 | a | 2770 | concrete +0,30 | K-21502 A/B | SK1710 | 2010-10-02 | 2010-11-30 | 2011-02-10 | 2011-02-10 | Zeppelin | K-21502 A/B | 1204 | 0 | 17 | EQ | X | B | 1710 | 12,038 |  |  |  |  |  |  |  |  |  |  |  |  |  |  |  |  |  |  |  |  |  |  |  |
| SE-21403A/B |  | FINES SEPARATOR |  | 10d | 2012-01-19 | 2012-01-30 | EX-21401, P3M01SA (other project), XN301710 SS+30d | -64d | 0d |  |  | Extruder [6 mhr]; Extruder [6 h] | 600 | 6,00 | a | 600 | structure +3.650 | SE-21403A/B | SK1710 |  |  |  |  |  | SE-21403A/B | 6 | 0 | 17 | EQ | X | U | 1710 | 0,6 |  |  |  |  |  |  |  |  |  |  |  |  |  |  |  |  |  |  |  |  |  |  |  |
| HO-21409 |  | OVERHEAD TRAVELLING CRANE |  | 10d | 2012-01-21 | 2012-02-01 | P3N02MN (other project), P3A12S1 (other project), XS401710 FF, XC701710 | 355.5d |  |  |  | Static Equipment < 10 tons [0.3 t]; Static equipment < 10t [30 h] | 1,200 | 30,00 |  | 6700 |  | HO-21409 | SK1710 |  | 2011-01-09 |  | 2011-02-01 |  | HO-21409 | 30 | 0 | 17 | EQ | X | B | 1710 |  |  |  |  |  |  |  |  |  |  |  |  |  |  |  |  |  |  |  |  |  |  |  |  |
| HO-21410 |  | OVERHEAD TRAVELLING CRANE |  | 10d | 2012-01-21 | 2012-02-01 | P3N02MN (other project), XS401710 FF, P3A12S1 (other project), XC701710 | 355.5d |  |  |  | Static Equipment < 10 tons [0.3 t]; Static equipment < 10t [30 h] | 1,200 | 30,00 |  | 6700 |  | HO-21410 | SK1710 |  | 2011-01-09 |  | 2011-02-01 |  | HO-21410 | 30 | 0 | 17 | EQ | X | B | 1710 |  |  |  |  |  |  |  |  |  |  |  |  |  |  |  |  |  |  |  |  |  |  |  |  |
| HO-21411 |  | OVERHEAD TRAVELLING CRANE |  | 10d | 2012-01-21 | 2012-02-01 | P3A12S1 (other project), XC701710, P3N02MN (other project), XS401710 FF | 355.5d |  |  |  | Static Equipment < 10 tons [0.3 t]; Static equipment < 10t [30 h] | 1,200 | 30,00 |  | 6700 |  | HO-21411 | SK1710 |  | 2011-01-09 |  | 2011-02-01 |  | HO-21411 | 30 | 0 | 17 | EQ | X | B | 1710 |  |  |  |  |  |  |  |  |  |  |  |  |  |  |  |  |  |  |  |  |  |  |  |  |
| HO-21412 |  | OVERHEAD TRAVELLING CRANE |  | 10d | 2012-01-21 | 2012-02-01 | XC701710, P3N02MN (other project), XS401710 FF, P3A12S1 (other project) | 355.5d |  |  |  | Static Equipment < 10 tons [0.3 t]; Static equipment < 10t [30 h] | 1,200 | 30,00 |  | 6700 |  | HO-21412 | SK1710 |  | 2011-01-09 |  | 2011-02-01 |  | HO-21412 | 30 | 0 | 17 | EQ | X | B | 1710 |  |  |  |  |  |  |  |  |  |  |  |  |  |  |  |  |  |  |  |  |  |  |  |  |
| HO-21413 |  | OVERHEAD TRAVELLING CRANE |  | 10d | 2012-01-21 | 2012-02-01 | XS401710 FF, XC701710, P3N02MN (other project), P3A12S1 (other project) | 355.5d |  |  |  | Static Equipment < 10 tons [0.3 t]; Static equipment < 10t [30 h] | 1,200 | 30,00 |  | 6700 |  | HO-21413 | SK1710 |  | 2011-01-09 |  | 2011-02-01 |  | HO-21413 | 30 | 0 | 17 | EQ | X | B | 1710 |  |  |  |  |  |  |  |  |  |  |  |  |  |  |  |  |  |  |  |  |  |  |  |  |
| HO-21416 |  | OVERHEAD TRAVELLING CRANE |  | 10d | 2012-01-21 | 2012-02-01 | XC701710, XS401710 FF, P3N02MN (other project), P3A12S1 (other project) | 355.5d |  |  |  | Static Equipment < 10 tons [0.3 t]; Static equipment < 10t [30 h] | 1,200 | 30,00 |  | 6700 |  | HO-21416 | SK1710 |  | 2011-01-09 |  | 2011-02-01 |  | HO-21416 | 30 | 0 | 17 | EQ | X | B | 1710 |  |  |  |  |  |  |  |  |  |  |  |  |  |  |  |  |  |  |  |  |  |  |  |  |
| HO-21417 |  | OVERHEAD TRAVELLING CRANE |  | 15d | 2012-01-21 | 2012-02-07 | P3N02MN (other project), XS401710 FF, P3A12S1 (other project), XC701710 | 350.5d |  |  |  | Static Equipment < 10 tons [7.3 t]; Static equipment < 10t [730 h] | 29,200 | 730,00 |  | 6700 |  | HO-21417 | SK1710 |  | 2011-01-09 |  | 2011-02-01 |  | HO-21417 | 730 | 0 | 17 | EQ | X | B | 1710 |  |  |  |  |  |  |  |  |  |  |  |  |  |  |  |  |  |  |  |  |  |  |  |  |
| HO-21418 |  | OVERHEAD TRAVELLING CRANE |  | 15d | 2012-01-21 | 2012-02-07 | XS401710 FF, P3N02MN (other project), XC701710, P3A12S1 (other project) | 350.5d |  |  |  | Static Equipment < 10 tons [6.7 t]; Static equipment < 10t [670 h] | 26,800 | 670,00 |  | 6700 | concrete +0,30 | HO-21418 | SK1710 |  | 2011-01-09 |  | 2011-02-01 |  | HO-21418 | 670 | 0 | 17 | EQ | X | B | 1710 |  |  |  |  |  |  |  |  |  |  |  |  |  |  |  |  |  |  |  |  |  |  |  |  |
| XB901710 |  | CA17 ExtrBldgFl1 - Install Overhead Crane | level of effort | 18d | 2012-01-21 | 2012-02-07 | HO-21410 FF, HO-21412 SS, HO-21409 FF, HO-21417 FF, HO-21418 SS, HO-21416 SS, HO-21411 SS, HO-21417 SS, HO-21416 FF, HO-21413 FF, HO-21410 SS, HO-21411 FF, HO-21413 SS, HO-21412 FF, HO-21409 SS, HO-21418 FF | 411.5d | 0d |  | TB26 - 3 - Construction Normal 7days * CA17 |  |  | 14 |  |  |  |  |  |  |  |  |  |  | XB901710 | 0 | 0 | 17 |  | X | B | 1710 |  | OMUS-1 | 2011-04-15 | 2011-09-30 | E-08-01-12 |  |  |  | 934 | XBB |  | 200 | 200 | C | LND | XB90 | B | 17 | X | EQ | LND | 1710 |  |  |
| TK-21402 |  | PELLETIZER WATER TANK |  | 10d | 2012-01-31 | 2012-02-10 | XN301710 SS+30d, SE-21403A/B SS+10d, XC20171015, EX-21401 | -64d | 0d |  |  | Extruder [50 h]; Extruder [50 mhr] | 5,000 | 50,00 | a | 5000 | concrete +0.30 | TK-21402 | SK1710 |  |  |  |  |  | TK-21402 | 50 | 0 | 17 | EQ | X | U | 1710 | 5 |  |  |  |  |  |  |  |  |  |  |  |  |  |  |  |  |  |  |  |  |  |  |  |
| HE-24501 |  | NITROGEN / MINERAL OIL HEATER (electrical) |  | 5d | 2012-02-10 | 2012-02-15 | XB00171005 SS, XB00171005 FF, XC20171015, K-21502 A/B, P3A06AS1 (other project) | -53d | 54d |  |  | Static Equipment < 10 tons [0.1 t]; Static equipment < 10t [10 h] | 400 | 10,00 | a | 6700 | concrete | HE-24501 | SK1710 |  | 2011-01-09 |  | 2011-02-01 |  | HE-24501 | 10 | 0 | 17 | EQ | X | B | 1710 | 0,1 |  |  |  |  |  |  |  |  |  |  |  |  |  |  |  |  |  |  |  |  |  |  |  |
| E-21901 |  | STEAM CONDENSER |  | 10d | 2012-02-18 | 2012-03-01 | P3A06S3 (other project), XB00171005 FF, XB00171005 SS, XN301710, V-21901 | -75d | 0d |  |  | Static Equipment < 10 tons [2.77 t]; Static equipment < 10t [277 h] | 11,080 | 277,00 | a | 2770 | structure +8.080 | E-21901 | SK1710 | 2010-10-02 | 2010-11-30 | 2011-02-10 | 2011-02-10 | Linde E. India | E-21901 | 277 | 0 | 17 | EQ | X | B | 1710 | 2,77 |  |  |  |  |  |  |  |  |  |  |  |  |  |  |  |  |  |  |  |  |  | 2 DD 8530 |  |
| E-22502 |  | TRANSFER AIR COOLER |  | 5d | 2012-02-18 | 2012-02-24 | XN301710, P3U10S2B (other project), XB00171005 SS, XB00171005 FF, K-22502 A/B, EX-22401-MI01 | -70d | 0d |  |  | Static Equipment < 10 tons [0.7 t]; Static equipment < 10t [70 h] | 2,800 | 70,00 | a | 700 | structure +5.750 | E-22502 | SK1710 |  |  |  |  | Zeppelin | E-22502 | 70 | 0 | 17 | EQ | X | B | 1710 | 0,7 |  |  |  |  |  |  |  |  |  |  |  |  |  |  |  |  |  |  |  |  |  | 2 DC 8990/ 4 | Zeppelin |
| V-22502 |  | TRANSFER AIR LIQUID SEPARATOR |  | 10d | 2012-02-25 | 2012-03-07 | XN301710, XB00171005 FF, XB00171005 SS, P3U10S2B (other project), E-22502 | -70d | 37d |  |  | Static Equipment < 10 tons; Static equipment < 10t |  | 0,00 | a | 2770 | concrete +4,75 | V-22502 | SK1710 | 2010-10-02 | 2010-11-30 | 2011-02-10 | 2011-02-10 | Zeppelin | V-22502 | 0 | 0 | 17 | EQ | X | B | 1710 | 0 |  |  |  |  |  |  |  |  |  |  |  |  |  |  |  |  |  |  |  |  |  |  |  |
| E-21502 |  | TRANSFER AIR COOLER |  | 5d | 2012-03-02 | 2012-03-07 | E-21901, EX-21401-MI01, XB00171005 SS, P3U10S1B (other project), XN301710, XB00171005 FF, K-21502 A/B | -75d | 0d |  |  | Static Equipment < 10 tons [0.7 t]; Static equipment < 10t [70 h] | 2,800 | 70,00 | a | 700 | structure +4.750 | E-21502 | SK1710 |  |  |  |  | Zeppelin | E-21502 | 70 | 0 | 17 | EQ | X | B | 1710 | 0,7 |  |  |  |  |  |  |  |  |  |  |  |  |  |  |  |  |  |  |  |  |  | 2 DC 8990/ 4 | Zeppelin |
| V-21502 |  | TRANSFER AIR LIQUID SEPARATOR |  | 5d | 2012-03-09 | 2012-03-14 | XN301710, XB00171005 SS, XB00171005 FF, P3U10S1B (other project), E-21502 | -75d | 32d |  |  | Static Equipment < 10 tons [0.28 t]; Static equipment < 10t [28 h] | 1,120 | 28,00 | a | 2770 | structure +4.75 | V-21502 | SK1710 | 2010-10-02 | 2010-11-30 | 2011-02-10 | 2011-02-10 | Zeppelin | V-21502 | 28 | 0 | 17 | EQ | X | B | 1710 | 0,28 |  |  |  |  |  |  |  |  |  |  |  |  |  |  |  |  |  |  |  |  |  |  |  |

Notes:
- K-22502 A/B: UDF_PACKAGE: PU10 CONVEYING SYSTEM (PK-21501) ZEPPELIN
- SE-22403A/B: UDF_PACKAGE: M01 EXTRUDER (EX-21-/22401)
- TK-22402: UDF_PACKAGE: M01 EXTRUDER (EX-21-/22401)
- XB00171005: Current Status: 110210 Start when paving inside will be finished (WL)
- V-21901: UDF_PACKAGE: A02A LARGE DRUMS (V-21701/24101/21901)
- MI-21402: UDF_PACKAGE: A13 SCALES (MI-21-/22104-6A/B)
- K-21502 A/B: UDF_PACKAGE: PU10 CONVEYING SYSTEM (PK-21501) ZEPPELIN
- SE-21403A/B: UDF_PACKAGE: M01 EXTRUDER (EX-21-/22401)
- HO-21409: UDF_PACKAGE: A12 OVERHEAD CRANES / TROLLEYS (incl. in Civil Subcontract)
- HO-21410: UDF_PACKAGE: A12 OVERHEAD CRANES / TROLLEYS (incl. in Civil Subcontract)
- HO-21411: UDF_PACKAGE: A12 OVERHEAD CRANES / TROLLEYS (incl. in Civil Subcontract)
- HO-21412: UDF_PACKAGE: A12 OVERHEAD CRANES / TROLLEYS (incl. in Civil Subcontract)
- HO-21413: UDF_PACKAGE: A12 OVERHEAD CRANES / TROLLEYS (incl. in Civil Subcontract)
- HO-21416: UDF_PACKAGE: A12 OVERHEAD CRANES / TROLLEYS (incl. in Civil Subcontract)
- HO-21417: UDF_PACKAGE: A12 OVERHEAD CRANES / TROLLEYS (incl. in Civil Subcontract)
- HO-21418: UDF_PACKAGE: A12 OVERHEAD CRANES / TROLLEYS (incl. in Civil Subcontract)
- XB901710: P3 Activity Log Info: earlier, together with precast concr. elements ?
- TK-21402: UDF_PACKAGE: M01 EXTRUDER (EX-21-/22401)
- HE-24501: UDF_PACKAGE: A06A NITROGEN / MINERAL OIL HEATER (ELECTRICAL)
- E-21901: UDF_PACKAGE: A06 R.START-UP GAS HEATER/STEAM CONDENSER (E-21-/22203/21901)
- E-22502: UDF_PACKAGE: PU10 CONVEYING SYSTEM (PK-21501) ZEPPELIN
- V-22502: UDF_PACKAGE: PU10 CONVEYING SYSTEM (PK-21501) ZEPPELIN
- E-21502: UDF_PACKAGE: PU10 CONVEYING SYSTEM (PK-21501) ZEPPELIN
- V-21502: UDF_PACKAGE: PU10 CONVEYING SYSTEM (PK-21501) ZEPPELIN

| ID | WBS | Activity | Type | Duration | Start | Finish | Predecessors | Complete | Total float | Free float | Constraint | Calendar | Resources | Cost | Actual cost | TB26 Ressource Budget | UDF_Weight (ton) | POSITION | WEIGHT | UDF_TAG No | UDF_Object No | UDF_PACKAGE | UDF_SAVE ACT ID | UDF_BUDGETED LABOR UNIT | UDF_ACTUAL LABOR UNIT | Constr. Area | Zeigen/n. Zeigen | WBS Phase | WBS Discipline | WBS Objects | UDF_CHECK BASELINE | UDF_SELECT | UDF_CONTRACT START DATE | UDF_CONTRACT FINISH DATE | UDF_CONTRACT ITEM | UDF_CONTRACT DATE PENALIZED | UDF_PENALIZED START | UDF_PENALIZED FINISH | Department | Type of Work | Inquiry/Order No | PMT-Area | PMT-Schedule Org | PMT-Phase | PMT-Respons. | WBS Type of Work | Russia WBS Discipline (Russia) | Russia Construction Area | Russia WBS Phase | IMS | UPT | Russia WBS Objects | UDF_LEVEL | UDF_PO No | UDF_DELIVERY DATE PO | UDF_DELIVERY DATE DISPATCH PLANNED | UDF_DELIVERY DATE TO SITE PLANNED | UDF_DELIVERY DATE SITE NEED DATE | UDF_SUPPLIER | UDF_COMMENTS_0827 | UDF_PLANNED START | UDF_PLANNED FINISH | Subcontractor | UDF_Vendor Representatives | UDF_CONTRACT FINISH DATE REV1 | UDF_CONTRACT START DATE REV1 | UDF_INDICATOR | TB26 Semantics | TB26 Material Res Values | UDF_ELECTRICAL START | UDF_ELECTRICAL FINISH |
| --- | --- | --- | --- | --- | --- | --- | --- | --- | --- | --- | --- | --- | --- | --- | --- | --- | --- | --- | --- | --- | --- | --- | --- | --- | --- | --- | --- | --- | --- | --- | --- | --- | --- | --- | --- | --- | --- | --- | --- | --- | --- | --- | --- | --- | --- | --- | --- | --- | --- | --- | --- | --- | --- | --- | --- | --- | --- | --- | --- | --- | --- | --- | --- | --- | --- | --- | --- | --- | --- | --- | --- |
|  | M | **Mechanical - Rotating Equipment** |  |  | 2011-12-12 | 2012-02-22 |  |  |  |  |  |  |  |  |  |  |  |  |  |  |  |  |  |  |  |  |  |  |  |  |  |  |  |  |  |  |  |  |  |  |  |  |  |  |  |  |  |  |  |  |  |  |  |  |  |  |  |  |  |  |  |  |  |  |  |  |  |  |  |  |  |
| P-21702 |  | SUBMERSIBLE PUMPS |  | 5d | 2011-12-12 | 2011-12-17 | XC20171010, EX-22401, P3M14S2 (other project), XC601710, XM00171005 SS, F4730 FF, XM00171005 FF |  | -7.88d | 99.12d |  |  | Rotating Equipment (w/o lube oil unit) [1.95 t]; Rotating equipment (w/o lube oil unit) [195.2 h] | 6,832 |  | 195,20 | 0,3 | a | 2240 | P-21702 | SK1710 | M14 SUBMERSIBLE PUMPS (P-21701/2/23601A/B/23801) | P-21702 | 195,2 | 0 | 17 | EQ | X | M | 1710 |  |  |  |  |  |  |  |  |  |  |  |  |  |  |  |  |  |  |  |  |  |  |  |  |  |  |  |  |  |  |  |  |  |  |  |  |  |  |  |  |  |
| SU-21701 |  | CHEMICAL WASTE WATER PIT |  | 10d | 2011-12-12 | 2011-12-23 | XM00171005 FF, EX-21401 FS-20d, F4730 FF, EX-22401 FS-20d, XM00171005 SS, XC601710, P3M14S2 (other project) |  | -27.88d | 0d |  |  | Rotating Equipment (w/o lube oil unit) [0.7 t]; Rotating equipment (w/o lube oil unit) [70 h] | 2,450 |  | 70,00 |  | a | 2240 | SU-21701 | SK1710 | M14 SUBMERSIBLE PUMPS (P-21701/2/23601A/B/23801) | SU-21701 | 70 | 0 | 17 | EQ | X | M | 1710 | x |  |  |  |  |  |  |  |  |  |  |  |  |  |  |  |  |  |  |  |  |  |  |  |  |  |  |  |  |  |  |  |  |  |  |  |  |  |  |  |  |
| SU-21702 |  | SUBMERSIBLE PUMPS |  | 10d | 2011-12-12 | 2011-12-23 | F4730 FF, XM00171005 FF, XC601710, P3M14S2 (other project), XC20171010, XM00171005 SS |  | -12.88d | 94.12d |  |  | Rotating Equipment (w/o lube oil unit) [0.7 t]; Rotating equipment (w/o lube oil unit) [70 h] | 2,450 |  | 70,00 | 0 | a | 2240 | SU-21702 | SK1710 | M14 SUBMERSIBLE PUMPS (P-21701/2/23601A/B/23801) | SU-21702 | 70 | 0 | 17 | EQ | X | M | 1710 |  |  |  |  |  |  |  |  |  |  |  |  |  |  |  |  |  |  |  |  |  |  |  |  |  |  |  |  |  |  |  |  |  |  |  |  |  |  |  |  |  |
| XM00171005 |  | CA17 ExtrBldgFl1 - Install Rotating Eqpt. | level of effort | 65d | 2011-12-13 | 2012-02-22 |  |  | -26d | 0d |  | TB26 - 3 - Construction Normal 7days * CA17 |  |  |  | 2 |  |  |  |  |  |  | XM00171005 | 0 | 0 | 17 |  | X | M | 1710 |  | OMUS-1 | 2011-04-15 | 2011-09-30 | E-08-01-12 | P | 2011-12-30 | 2011-12-30 | 934 | XBB | 2DC8480 | 200 | 200 | C | LND | XM00 | M | 17 | X | EQ | LND | 1710 |  |  |  |  |  |  |  |  |  |  |  |  |  |  |  |  |  |  |  |
| K-24101A/B/C |  | INSTRUMENT AIR COMPRESSOR |  | 10d | 2011-12-23 | 2012-01-11 | XC20171015, TK-22402, P3M16S (other project), XM00171005 FF, XM00171005 SS, F4730 FF, EX-22401, SE-22403A/B |  | -22.88d | 84.12d |  |  | Rotating Equipment (w/ lube oil unit) [2 t]; Rotating equipment (w/ lube oil unit) [175 h] | 8,000 |  | 175,00 | 2 | a | 2000 | K-24101A/B/C | SK1710 | M16 INSTRUMENT AIR COMPRESSOR (K-24101) | K-24101A/B/C | 175 | 0 | 17 | EQ | X | M | 1710 |  |  |  |  |  |  |  |  |  |  |  |  |  |  |  |  |  |  |  |  |  |  | concrete +0.30 | 2 KB 4660 / 2 | 2011-01-17 | 2011-01-17 | 2011-03-13 | 2011-03-20 | Aerzener |  |  |  |  |  |  |  |  |  |  |  |  |
| P-22402A/B |  | PELLETIZER WATER PUMPS |  | 10d | 2011-12-23 | 2012-01-11 | XM00171005 FF, XM00171005 SS, XC20171015, TK-22402, SE-22403A/B, P3M01SA (other project) |  | -27.88d | 0d |  |  | Extruder [44.65 h]; Extruder [44.65 mhr] | 4,465 |  | 44,80 | 2,24 | a | 2240 | P-22402A/B | SK1710 | M01 EXTRUDER (EX-21-/22401) | P-22402A/B | 44,65 | 0 | 17 | EQ | X | M | 1710 |  |  |  |  |  |  |  |  |  |  |  |  |  |  |  |  |  |  |  |  |  |  | concrete +0.30 |  |  |  |  |  |  |  |  |  |  |  |  |  |  |  |  |  |  |
| P-21901A/B |  | CONDENSATE PUMP |  | 10d | 2012-01-11 | 2012-01-21 | XM00171005 SS, XM00171005 FF, XC20171015, V-21901, XN301710 SS+20d, P3M15S2 (other project), F4730 FF |  | -32d | 0d |  |  | Rotating Equipment (w/o lube oil unit) [6.51 t]; Rotating equipment (w/o lube oil unit) [650.1 h] | 22,771 |  | 650,10 | 1 | a | 1000 | P-21901A/B | SK1710 | M15 CONDENSATE / SERVICE WATER PUMP (P-21901A/B/23401) | P-21901A/B | 650,1 | 0 | 17 | EQ | X | M | 1710 |  |  |  |  |  |  |  |  |  |  |  |  |  |  |  |  |  |  |  |  |  |  | concrete +0.30 | 2 PA 6720 / 1 | 2010-10-15 | 2010-11-26 | 2010-12-15 | 2011-03-20 | KSB |  |  |  |  |  |  |  |  |  |  |  |  |
| P-21402A/B |  | PELLETIZER WATER PUMPS |  | 10d | 2012-02-11 | 2012-02-22 | SE-21403A/B, TK-21402, XM00171005 FF, XM00171005 SS, XC20171015, P3M01SA (other project) |  | -64d | 0d |  |  | Extruder [44.65 h]; Extruder [44.65 mhr] | 4,465 |  | 44,80 | 2,24 | a | 2240 | P-21402A/B | SK1710 | M01 EXTRUDER (EX-21-/22401) | P-21402A/B | 44,65 | 0 | 17 | EQ | X | M | 1710 |  |  |  |  |  |  |  |  |  |  |  |  |  |  |  |  |  |  |  |  |  |  | concrete +0.30 |  |  |  |  |  |  |  |  |  |  |  |  |  |  |  |  |  |  |
|  | R | **Piping** |  |  | 2011-09-18 | 2012-06-05 |  |  |  |  |  |  |  |  |  |  |  |  |  |  |  |  |  |  |  |  |  |  |  |  |  |  |  |  |  |  |  |  |  |  |  |  |  |  |  |  |  |  |  |  |  |  |  |  |  |  |  |  |  |  |  |  |  |  |  |  |  |  |  |  |  |
| XR201710 |  | CA17 ExtrBldgFl1 - Piping Prefabrication |  | 200d | 2011-09-18 | 2012-04-14 | P3R06AS (other project), ER49171005 (other project) SS+18d, P3U10S1C (other project), ER491710 (other project) SS+18d, P3R06S (other project), P3R06DS (other project), EL1040 (other project) FF+20d, XR500C00 FS+15d |  | -115d | 0d | as late as possible | TB26 - 3 - Construction Normal 7days * CA17 | A/G piping prefabrication [8750 Fpi]; Conveying S. piping prefabrication [350 Fpi]; A/G Piping (Prefab) [32812.5 h]; Conveying system (Prefab) [875 h] | 56,208.13 |  | 33687,50 |  |  |  |  |  |  | XR201710 | 33687,5 | 0 | 17 |  | X | R | 1710 |  | OMUS-1 |  |  |  |  |  |  | 934 | PU10 | 2DC8990 | 200 | 200 | C | LND | XR20 | R | 17 | X | PRP | LND | 1710 |  |  |  |  |  |  |  | Start mid of sept |  |  |  |  |  |  |  |  |  |  |  |
| XR401710 |  | CA17 ExtrBldgFl1 - Piping Installation |  | 170d | 2011-11-18 | 2012-05-16 | XC191710, EX-22401-MI04 FF+20d, EX-22401-MI01 FF+20d, E-21901 FF+20d, E-22502 FF+20d, V-22502 FF+20d, V-21502 FF+20d, XR201710 SS+40d, P3J02BS (other project), EX-22401-PE01 FF+20d, EX-21401-G01 FF+20d, MI-21402 FF+20d, K-21502 A/B FF+20d, P3R07BS (other project) FF+30d, P3J02AS (other project), P3J04CS1 (other project), XC701710 FF+15d, XN601710 FF+30d, E-21402A/B FF+20d, EX-21401-SE01 FF+20d, K-22502 A/B FF+20d, P3J02S (other project), P3J02DS (other project), EX-22401-MX01 FF+20d, EX-22401-SE01 FF+20d, EX-21401 FF+20d, EX-21401-PE01 FF+20d, EX-21401-MI04 FF+20d, K-24101A/B/C FF+20d, P-21702 FF+20d, SU-21702 FF+20d, P-23401 FF+20d, P3J04AS (other project), P3J04ES (other project), EX-21401-MX01 FF+20d, E-21502 FF+20d, SE-22403A/B FF+20d, P-21402A/B FF+20d, P-22402A/B FF+20d, P3R04S (other project) FF+20d, P3J04BS (other project), XX-21701 FF+20d, EX-22401-MI03 FF+20d, EX-21401-MI01 FF+20d, EX-21401-M01 FF+20d, EX-21401-MI02 FF+20d, P-21901A/B FF+20d, SU-21701 FF+20d, P3S07S (other project) FF+20d, P3S06S (other project) FF+20d, E-22402A/B FF+20d, EX-22401-G01 FF+20d, EX-22401-M01 FF+20d, EX-21401-MI03 FF+20d, HE-24501 FF+20d, XR201710 FF+20d, XR401707 FF+10d, XC601710 FS-25d, EX-22401 FF+20d, EX-22401-MI02 FF+20d, SE-21403A/B FF+20d, TK-21402 FF+20d, TK-22402 FF+20d, V-21901 FF+20d, IMS-C-000190 FF, P3J01AS (other project), P3J02CS (other project), P3J04IS (other project), P3R09AS (other project) FF+20d |  | -125d | 0d |  | TB26 - 3 - Construction Normal 7days * CA17 | A/G piping field installation [10700 Fpi]; Conveying S. piping field installation [400 Fpi]; Control & Shut-off valves [39 pcs]; A/G Piping (Field) [66875 h]; Conveying system (Field) [2000 h]; Install Control & Shut-off Valves [204.75 h] | 143,591.76 |  | 69079,75 |  |  |  |  |  |  | XR401710 | 69079,75 | 0 | 17 |  | X | R | 1710 |  | OMUS-1 | 2011-02-25 |  | E-06-03-07 |  |  |  | 934 |  | 2DC8480 | 200 | 200 | C | LND | XR40 | R | 17 | X | PI | LND | 1710 |  |  |  |  |  |  |  |  | 2011-05-12 |  |  |  |  |  |  |  |  |  |  |
| XR601710 |  | CA17 ExtrBldgFl1 - Piping Pressure Tests |  | 100d | 2012-02-13 | 2012-05-26 | XR401710 FS-90d |  | -87d | 0d |  | TB26 - 3 - Construction Normal 7days * CA17 |  |  |  | 1677 |  |  |  |  |  |  | XR601710 | 0 | 0 | 17 |  | X | R | 1710 |  | OMUS-1 |  |  | E-06-03-07 |  |  |  | 934 |  | 2DC8480 | 200 | 200 | C | LND | XR60 | R | 17 | X | HY | LND | 1710 |  |  |  |  |  |  |  |  |  |  |  |  |  |  |  |  |  |  |  |
| XR801710 |  | CA17 ExtrBldgFl1 - Piping Reinstatement |  | 60d | 2012-04-05 | 2012-06-05 | IMS-C-000190 FF, IMS-C-000360 FF, XR601710 FS-50d |  | -87d | 0d |  | TB26 - 3 - Construction Normal 7days * CA17 |  |  |  | 838 |  |  |  |  |  |  | XR801710 | 0 | 0 | 17 |  | X | R | 1710 |  | OMUS-1 |  | 2012-02-25 | E-06-03-07 |  |  |  | 934 |  | 2DC8480 | 200 | 200 | C | LND | XR80 | R | 17 | X | PI | LND | 1710 |  |  |  |  |  |  |  |  |  | 2012-05-11 |  |  |  |  |  |  |  |  |  |
|  | E | **Electrical** |  |  | 2010-08-13 | 2012-09-11 |  |  |  |  |  |  |  |  |  |  |  |  |  |  |  |  |  |  |  |  |  |  |  |  |  |  |  |  |  |  |  |  |  |  |  |  |  |  |  |  |  |  |  |  |  |  |  |  |  |  |  |  |  |  |  |  |  |  |  |  |  |  |  |  |  |
| XC911710 |  | CA17 ExtrBldgFl1 - Install EarthingSys_CIVIL |  | 42d | 2010-08-13 A | 2010-09-23 A | EE900010 (other project), EE901710 (other project), XC20171005 SS+10d, XC20171005 FF+10d | 100% |  |  |  | TB26 - 3 - Construction Normal 7days * CA17 | Grounding & Lightning [90 pcs]; Grounding & Lightning [1012.5 h] | 40,500 | 40,500 | 1012,50 |  |  |  |  |  |  | XC911710 | 1012,5 | 1012,5 | 17 |  | X | C | 1710 |  |  | 2011-06-10 | 2012-01-20 | E-16-07-07 |  |  |  | 934 |  |  | 200 | 200 | C | LND | XE91 | C | 17 | X | EA | LND | 1710 |  |  |  |  |  |  |  |  |  |  | MO11 |  |  |  |  |  |  |  |  |
| XC91171005 |  | CA17 ExtrBldgFl1 - Install LightningSys |  | 40d | 2011-12-05 | 2012-01-20 | XC501710 SS+20d |  | 7d | 0d |  | TB26 - 3 - Construction Normal 7days * CA17 | Grounding & Lightning [150 pcs]; Grounding & Lightning [1687.5 h] | 67,500 |  | 1687,50 |  |  |  |  |  |  | XC91171005 | 1687,5 | 0 | 17 |  | X | C | 1710 |  | REL XC50 | 2011-06-10 | 2012-01-20 | E-16-07-07 |  |  |  | 934 |  |  | 200 | 200 | C | LND | XE91 | E | 17 | X | EA | LND | 1710 |  |  |  |  |  |  |  |  |  |  | URMA |  |  |  |  |  |  |  |  |
| XE801710 |  | CA17 ExtrBldgFl1 - Install Heat Tracing |  | 40d | 2012-02-13 | 2012-03-25 | IMS-C-000280 SS, IMS-C-000260 FF, P3E19S (other project), XR601700, XW501710 SS+20d, E3E1950 (other project), XR401720 FS-40d |  | 19d | 0d |  | TB26 - 3 - Construction Normal 7days * CA17 | Electrical Heat Tracing [900 m]; Electrical heat tracing [450 h] | 18,000 |  | 450,00 |  |  |  |  |  |  | XE801710 | 450 | 0 | 17 |  | X | E | 1710 |  |  | 2011-06-20 | 2012-03-20 | E-16-04-01 |  |  |  | 934 |  | 2DC8480 | 200 | 200 | C | LND | XE80 | E | 17 | X | HT | LND | 1710 |  |  |  |  |  |  |  |  |  |  | URMA | 005 | 2012-06-30 | 2011-09-15 | UDF_G3 |  |  |  |  |
| XE401710 |  | CA17 ExtrBldgFl1 - Install Cable Trays |  | 30d | 2012-02-15 | 2012-03-17 | XC50171010, EE46171010 (other project), EE46510120 (other project) FF, XH00171007 FS-10d, XH00171006 FS-10d, P3E16S (other project), XC50171005, XN301710 FS-20d, XR401710 FS-95d |  | -92d | 0d |  | TB26 - 3 - Construction Normal 7days * CA17 | Cable trays/conduits [1680 m]; Cable trays [5040 h] | 201,600 |  | 5040,00 |  |  |  |  |  |  | XE401710 | 5040 | 0 | 17 |  | X | E | 1710 | x | REL XC50 | 2011-06-10 | 2011-11-30 | E-15-01-11 |  |  |  | 934 |  | 2DC8480 | 200 | 200 | C | LND | XE40 | E | 17 | X | EL | LND | 1710 |  |  |  |  |  |  |  | after equipm. erection & 50% piping |  |  | URMA |  | 2012-04-01 | 2011-09-20 | UDF_G1 | m | 4200 | 2011-08-13 | 2011-10-31 |
| XE911711 |  | CA17 ExtrBldgFl1 - Install EarthingSys_E/I |  | 20d | 2012-02-18 | 2012-03-10 | XC701710, XN301710, EX-21401, XB00171005 |  | 109d | 220.5d |  | TB26 - 3 - Construction Normal 7days * CA17 |  |  |  | 265 |  |  |  |  |  |  | XE911711 | 0 | 0 | 17 |  | X | E | 1710 |  |  | 2011-06-10 | 2012-01-20 | E-16-07-07 |  |  |  | 934 |  |  | 200 | 200 | C | LND | XE91 | E | 17 | X | EA | LND | 1710 |  |  |  |  |  |  |  |  |  |  | URMA |  | 2012-07-15 | 2011-09-20 | UDF_G3 |  |  |  |  |
| XE201710 |  | CA17 ExtrBldgFl1 - Install temp. LV-power generation CA17 |  | 50d | 2012-02-26 | 2012-04-16 | XH00171006, XE401710 SS, XH00171007, P3E07S2 (other project), XC911710, X3E105 FF, P3E02S3 (other project) |  | -80d | 49.5d |  | TB26 - 3 - Construction Normal 7days * CA17 | Main Equipment Substations [4 pcs]; Installation main equipment substation [150 h] | 6,000 |  | 150,00 |  |  |  |  |  |  | XE201710 | 150 | 0 | 17 |  | X | E | 1710 |  |  | 2011-06-10 | 2012-01-20 | E-16-07-07 |  |  |  | 934 |  |  | 200 | 200 | C | LND | XE20 | E | 17 | X | EL | LND | 1710 |  |  |  |  |  |  |  | after equipm. erection & 50% piping |  |  | URMA |  | 2012-07-15 | 2011-09-20 | UDF_G2 |  |  |  |  |
| XE701710 |  | CA17 ExtrBldgFl1 - Install Lighting &Small Power |  | 50d | 2012-03-07 | 2012-04-26 | XE401710 FS-10d, EE761700 (other project), EE76510110 (other project) FF+20d, XH00171005 FS-30d, XP341610 FS+50d, P3E09S (other project), P3E03S2 (other project) FF+20d, EE76170010 (other project) FF+20d, XC50171005 |  | 2d | 74.5d |  | TB26 - 3 - Construction Normal 7days * CA17 | Lighting illuminates [150 pcs]; Lighting (iluminates) [1500 h] | 60,000 |  | 1500,00 |  |  |  |  |  |  | XE701710 | 1500 | 0 | 17 |  | X | E | 1710 |  |  | 2011-05-10 | 2012-01-31 | E-16-03-01 |  |  |  | 934 |  |  | 200 | 200 | C | LND | XE70 | E | 16 | X | EL | LND | 1610 |  |  |  |  |  |  |  |  |  |  | URMA |  | 2012-05-10 | 2011-08-15 | UDF_G2 |  |  |  |  |
| XE341710 |  | CA17 ExtrBldgFl1 - Install Local Operation Panels |  | 50d | 2012-03-18 | 2012-05-07 | EE46171010 (other project), XE401710, XR401710 FS-80d, XM00171005 SS+20d, XB00171005 SS+20d |  | -8d | 64.5d |  | TB26 - 3 - Construction Normal 7days * CA17 | Field Panels [11 pcs]; Field panels [220 h] | 8,800 |  | 220,00 |  |  |  |  |  |  | XE341710 | 220 | 0 | 17 |  | X | E | 1710 |  |  | 2011-06-10 | 2012-01-20 | E-16-07-07 |  |  |  | 934 |  | 2DC8480 | 200 | 200 | C | LND | XE34 | E | 17 | X | EL | LND | 1710 |  |  |  |  |  |  |  | after equipm. erection & 50% piping |  |  | URMA |  | 2012-07-15 | 2011-09-20 |  |  |  |  |  |
| XE50171010 |  | CA17 ExtrBldgFl1 - Cable Pulling Electric Part II (over SR1708) |  | 35d | 2012-06-07 | 2012-07-19 | XE201710, P3E15BS (other project), XE401710 FF+20d, P3E15AS (other project), EE561710 (other project), XE501708 SS+6d, XE500C01, P3E15CS (other project) |  | -51.5d | 10d |  | TB26 - V - Construct-Winter partly * | Cable Pulling [17300 m]; Cable pulling [8650 h] | 346,000 |  | 8650,00 |  |  |  |  |  |  | XE50171010 | 8650 | 0 | 17 |  | X | E | 1710 |  |  | 2011-05-20 | 2012-02-10 | E-16-01-01 |  |  |  | 934 |  | 2DC8480 | 200 | 200 | C | LND | XE50 | E | 17 | X | EL | LND | 1710 |  |  |  |  |  |  |  |  |  |  | URMA |  | 2012-07-01 | 2011-10-01 | UDF_G2 | m | 17890 | 2012-01-16 | 2012-03-21 |
| XE50171005 |  | CA17 ExtrBldgFl1 - Cable Pulling Electric Part I (over SR1707) |  | 35d | 2012-06-20 | 2012-07-31 | XE401710 FF+20d, P3E15BS (other project), P3E15CS (other project), P3E15AS (other project), EE561710 (other project), XE500C01, XE201710, XE501707 SS+6d |  | -61.5d | 0d |  | TB26 - V - Construct-Winter partly * | Cable pulling [8650 h]; Cable Pulling [17300 m] | 346,000 |  | 8650,00 |  |  |  |  |  |  | XE50171005 | 8650 | 0 | 17 |  | X | E | 1710 |  |  | 2011-05-20 | 2012-02-10 | E-16-01-01 |  |  |  | 934 |  | 2DC8480 | 200 | 200 | C | LND | XE50 | E | 17 | X | EL | LND | 1710 |  |  |  |  |  |  |  |  |  |  | URMA |  | 2012-07-01 | 2011-10-01 | UDF_G2 | m | 17890 | 2011-10-31 | 2012-01-17 |
| XE601710 |  | CA17 ExtrBldgFl1 - Cable Termination & Testing |  | 60d | 2012-07-13 | 2012-09-11 | XE50171010 FS-15d, XE50171005 FS-15d, XE701710, IMS-C-000380 FF, XE341710, XE201710 |  | -72.5d | 39d |  | TB26 - 3 - Construction Normal 7days * CA17 | Cable connecting [210 pcs]; Cable connecting [525 h] | 21,000 |  | 525,00 |  |  |  |  |  |  | XE601710 | 525 | 0 | 17 |  | X | E | 1710 |  |  | 2011-04-20 | 2011-11-30 | E-16-02-01 |  |  |  | 934 |  | 2DC8480 | 200 | 200 | C | LND | XE60 | E | 17 | X | ET | LND | 1710 |  |  |  |  |  |  |  |  |  |  | URMA |  | 2012-08-14 | 2011-12-10 | UDF_G2 |  |  |  |  |

Notes:
- XM00171005: Current Status: 110210 Start when paving inside will be finished (WL)
- XE801710: UDF_PREDECESSOR: XR40, Piping 50% pressure tests
- XE401710: UDF_PREDECESSOR: XN30, Piping 50%
- XE911711: UDF_PREDECESSOR: XN30, DEL XE40, DEL XE80, DEL XJ40, Civil 100%, Equipment 100%
- XE201710: UDF_PREDECESSOR: after equipm. erection & 50% piping
- XE701710: UDF_PREDECESSOR: XE40, Civil 100%, HVAC ducts, Finishing works partly
- XE341710: UDF_PREDECESSOR: XE40, Equipment 100%, Piping 50%
- XE50171010: UDF_PREDECESSOR: XE40, XE50, DEL XE34
- XE50171005: UDF_PREDECESSOR: XE40, XE50, DEL XE34
- XE601710: UDF_PREDECESSOR: XE50, Equipment 100%

| ID | WBS | Activity | Duration | Start | Finish | Predecessors | Complete | Planned start | Planned finish | Total float | Free float | Calendar | Resources | Cost | Actual cost | TB26 Ressource Budget | UDF_CONTRACT START DATE | UDF_CONTRACT FINISH DATE | UDF_CONTRACT ITEM | UDF_CONTRACT FINISH DATE REV1 | UDF_CONTRACT START DATE REV1 | UDF_SAVE ACT ID | UDF_BUDGETED LABOR UNIT | UDF_ACTUAL LABOR UNIT | UDF_COMMENTS_0827 | UDF_PREDECESSOR | UDF_INDICATOR | Department | Constr. Area | PMT-Area | PMT-Schedule Org | PMT-Phase | PMT-Respons. | WBS Phase | WBS Discipline | WBS Type of Work | WBS Objects | Russia WBS Discipline (Russia) | Russia Construction Area | Russia WBS Phase | IMS | UPT | Russia WBS Objects | Subcontractor | TB26 Semantics | TB26 Material Res Values | UDF_ELECTRICAL START | UDF_ELECTRICAL FINISH | UDF_CHECK BASELINE | Inquiry/Order No | UDF_PENALIZED FINISH | UDF_SELECT | UDF_Text4 | Civil item | UDF_CONTRACT INDICATOR | UDF_SELECT UPDATE PROGRESS | UDF_CHECK RESOURCE DATES | Zeigen/n. Zeigen | UDF_Concrete |
| --- | --- | --- | --- | --- | --- | --- | --- | --- | --- | --- | --- | --- | --- | --- | --- | --- | --- | --- | --- | --- | --- | --- | --- | --- | --- | --- | --- | --- | --- | --- | --- | --- | --- | --- | --- | --- | --- | --- | --- | --- | --- | --- | --- | --- | --- | --- | --- | --- | --- | --- | --- | --- | --- | --- | --- | --- | --- | --- | --- |
|  | J | **Instrumentation** |  | 2012-03-16 | 2012-12-15 |  |  |  |  |  |  |  |  |  |  |  |  |  |  |  |  |  |  |  |  |  |  |  |  |  |  |  |  |  |  |  |  |  |  |  |  |  |  |  |  |  |  |  |  |  |  |  |  |  |  |  |  |  |  |
| XJ321710 |  | CA17 ExtrBldgFl1 - Install Junction Boxes | 40d | 2012-03-16 | 2012-04-24 | EJ321710 (other project), P3J06FS (other project), XR401710 FS-60d, P3J06ES (other project) FS+14d, EJ32171005 (other project) |  |  |  | -125d | 0d | TB26 - 3 - Construction Normal 7days * CA17 | Junction Boxes/Cabinets/Panels [86 pcs]; Install Junction Boxes/ Cabinets/ Panels [2150 h] | 86,000 |  | 2150,00 | 2011-06-10 | 2012-03-20 | E-17-04-07 | 2012-07-20 | 2011-10-15 | XJ321710 | 2150 | 0 | Civil 100%, Equipment 100%, Piping 50% | Civil 100%, Equipment 100%, Piping 50% | UDF_G1 | 934 | 17 | 200 | 200 | C | LND | X | J | XJ32 | 1710 | J | 17 | X | IN | LND | 1710 | URMA |  |  |  |  |  |  |  |  |  |  |  |  |  |  |  |
| XJ201710 |  | CA17 ExtrBldgFl1 - Install System/ IC/ PD Cabinets | 40d | 2012-04-05 | 2012-05-16 | XJ421710 FF, P3J06S2 (other project), XC911710, XH00171005 FF+30d, P3J05S (other project), P3J06AS (other project), P3J06CS1 (other project) |  |  |  | -125d | 0d | TB26 - 3 - Construction Normal 7days * CA17 | Junction Boxes/Cabinets/Panels [49 pcs]; Main Equipment Control Building/RIB [4100 mhr]; Install Junction Boxes/ Cabinets/ Panels [1225 h]; Installation Main Equipment Control Building/RIB [4100 h] | 459,000 |  | 5325,00 | 2011-06-10 | 2012-03-20 | E-17-04-07 | 2012-07-20 | 2011-10-15 | XJ201710 | 5325 | 0 |  |  |  | 934 | 17 | 200 | 200 | C | LND | X | J | XJ20 | 1710 | J | 17 | X | EL | LND | 1710 | URMA |  |  |  |  |  |  |  |  |  |  |  |  |  |  |  |
| XJ421710 |  | CA17 ExtrBldgFl1 - Install Secondary Cable Trays | 40d | 2012-04-05 | 2012-05-16 | XE401710 FS-15d, EJ46171010 (other project), XJ321710 FS-20d, EJ141710 (other project), XR401710 FS-95d |  |  |  | -125d | 0d | TB26 - 3 - Construction Normal 7days * CA17 | Secondary cable trays [1300 m]; Install secondary cable trays [4875 h] | 195,000 |  | 4875,00 | 2011-06-10 | 2011-11-30 | E-15-01-11 | 2012-04-01 | 2011-09-20 | XJ421710 | 4875 | 0 |  | XE40, XJ32, Equipment 100%, Piping 50% | UDF_G1 | 934 | 17 | 200 | 200 | C | LND | X | J | XJ42 | 1710 | J | 17 | X | IN | LND | 1710 | URMA | m | 2019 | 2011-08-13 | 2011-10-31 | x |  |  |  |  |  |  |  |  |  |  |
| XJ441710 |  | CA17 ExtrBldgFl1 - Install Conduits to Instrm | 70d | 2012-04-25 | 2012-07-06 | XJ321710, XE401710, XR401710 FS-95d |  |  |  | -92d | 0d | TB26 - 3 - Construction Normal 7days * CA17 |  |  |  |  | 2011-06-10 | 2012-03-20 | E-17-04-07 | 2012-07-20 | 2011-10-15 | XJ441710 | 0 | 0 |  | XE40, XJ32, XJ40, Equipment 100%, Piping 50% | UDF_G1 | 934 | 17 | 200 | 200 | C | LND | X | J | XJ44 | 1710 | J | 17 | X | IN | LND | 1710 | URMA |  |  |  |  |  |  |  |  |  |  |  |  |  |  |  |
| XJ301710 |  | CA17 ExtrBldgFl1 - Install Field Instruments | 70d | 2012-05-06 | 2012-07-16 | P3J05S (other project), P3J07CS (other project), XR401710 FS-95d, IMS-C-000340 FF, P3J04BS (other project), P3J07BS (other project), EJ361710 (other project), XR801710 FS-30d, V-21502 FS-10d |  |  |  | -87d | 0d | TB26 - 3 - Construction Normal 7days * CA17 | Field Instruments [120 pcs]; Install field instruments [660 h] | 26,400 |  | 660,00 | 2011-06-10 | 2012-03-20 | E-17-04-07 | 2012-07-20 | 2011-10-15 | XJ301710 | 660 | 0 | to be installed later | XR80, XR40, Equipment 100%, Piping 50% | UDF_G1 | 934 | 17 | 200 | 200 | C | LND | X | J | XJ30 | 1710 | J | 17 | X | IN | LND | 1710 | URMA |  |  |  |  |  | 2DC8480 |  |  |  |  |  |  |  |  |  |
| XJ8017115 |  | CA17 ExtrBldgFl1 - SAT System/ IC/ PD Cabinets | 7d | 2012-05-17 | 2012-05-23 | XJ201710 |  |  |  | 2d | 118.5d | TB26 - 3 - Construction Normal 7days * CA17 |  |  |  | 5325,00 | 2011-06-10 | 2012-03-20 | E-17-04-07 | 2012-07-20 | 2011-10-15 | XJ201710 | 5325 | 0 |  |  |  | 934 | 17 | 200 | 200 | C | LND | X | J | XJ20 | 1710 | J | 17 | X | EL | LND | 1710 | URMA |  |  |  |  |  |  |  |  |  |  |  |  |  |  |  |
| XJ541710 |  | CA17 ExtrBldgFl1 - Pulling Singlecore Cables | 90d | 2012-06-01 | 2012-09-14 | XJ441710 FS-35d, EJ801710 (other project), XJ301710 FS-50d, XJ421710, XE500C01 |  |  |  | -74d | 0d | TB26 - V - Construct-Winter partly * | Singlecore cables [10900 m]; Pull singlecore cables [8175 h] | 327,000 |  | 8175,00 | 2011-06-10 | 2012-03-20 | E-17-04-07 | 2012-07-20 | 2011-10-15 | XJ541710 | 8175 | 0 |  | XJ30, XJ42, XJ44 | UDF_G1 | 934 | 17 | 200 | 200 | C | LND | X | J | XJ54 | 1710 | J | 17 | X | IN | LND | 1710 | URMA | m | 10500 | 2011-12-02 | 2012-03-29 |  | 2DC8480 |  |  |  |  |  |  |  |  |  |
| XJ701710 |  | CA17 ExtrBldgFl1 - Instrument Tubing | 40d | 2012-06-06 | 2012-07-16 | XJ301710 FS-40d |  |  |  | -76d | 10d | TB26 - 3 - Construction Normal 7days * CA17 |  |  |  |  | 2011-06-10 | 2012-03-20 | E-17-04-07 | 2012-07-20 | 2011-10-15 | XJ701710 | 0 | 0 | to be installed later | XJ30 | UDF_G1 | 934 | 17 | 200 | 200 | C | LND | X | J | XJ70 | 1710 | J | 17 | X | IN | LND | 1710 | URMA |  |  |  |  |  |  |  |  |  |  |  |  |  |  |  |
| XJ391710 |  | CA17 ExtrBldgFl1 - Install Earthing Field Eqpt | 40d | 2012-07-07 | 2012-08-15 | XJ201710 FF+10d, XJ301710 FF, XJ421710, XJ441710 |  |  |  | -86d | 0d | TB26 - 3 - Construction Normal 7days * CA17 |  |  |  |  | 2011-06-10 | 2012-03-20 | E-17-04-07 | 2012-07-20 | 2011-10-15 | XJ391710 | 0 | 0 |  | XJ30, XJ42, XJ44, DEL XJ32, DEL XR40 | UDF_G1 | 934 | 17 | 200 | 200 | C | LND | X | J | XJ39 | 1710 | J | 17 | X | IN | LND | 1710 | URMA |  |  |  |  |  |  |  |  |  |  |  |  |  |  |  |
| XJ641710 |  | CA17 ExtrBldgFl1 - Termin Singlecore Cables | 80d | 2012-07-07 | 2012-09-24 | XJ541710 FS-60d, XJ301710 FF+15d, XJ321710, XJ391710 FS-40d, XJ701710 FS-20d |  |  |  | -86d | 25.5d | TB26 - 3 - Construction Normal 7days * CA17 | Termination Field [2825 mhr]; Termination field [2825 h] | 282,500 |  | 2825,00 | 2011-06-10 | 2012-03-20 | E-17-04-07 | 2012-07-20 | 2011-10-15 | XJ641710 | 2825 | 0 |  | XJ30, XJ32, XJ39, XJ54, XJ70 | UDF_G1 | 934 | 17 | 200 | 200 | C | LND | X | J | XJ64 | 1710 | J | 17 | X | IN | LND | 1710 | URMA |  |  |  |  |  | 2DC8480 |  |  |  |  |  |  |  |  |  |
| XJ521710 |  | CA17 ExtrBldgFl1 - Pulling Multicore Cables | 90d | 2012-07-16 | 2012-10-29 | XH00171005, XJ521707 FS-10d, XJ521708 FS-10d, XJ201710 SS, XJ321710 SS, P3J17S1 (other project), XE500C01, XE401708, XE401707 |  |  |  | -99.5d | 0d |  | Multicore cables [13100 m]; Pull multicore cables [6550 h] | 262,000 |  | 6550,00 | 2011-05-20 | 2012-03-10 | E-17-01-01 | 2012-06-16 | 2011-11-01 | XJ521710 | 6550 | 0 |  | XE40, XJ32, XJ52 | UDF_G1 | 934 | 17 | 200 | 200 | C | LND | X | J | XJ52 | 1710 | J | 17 | X | IN | LND | 1710 | URMA | m | 9500 | 2011-10-22 | 2012-02-16 |  | 2DC8480 |  |  |  |  |  |  |  |  |  |
| XJ621710 |  | CA17 ExtrBldgFl1 - Termin Multicore Cables | 80d | 2012-08-31 | 2012-11-20 | XJ521710 FS-50d, XJ321710 |  |  |  | -116.5d | 0d | TB26 - 3 - Construction Normal 7days * CA17 | Termination Field [2825 mhr]; Termination field [2825 h] | 282,500 |  | 2825,00 | 2011-05-20 | 2012-03-10 | E-17-01-01 | 2012-06-16 | 2011-11-01 | XJ621710 | 2825 | 0 |  | XJ32, XJ52 | UDF_G1 | 934 | 17 | 200 | 200 | C | LND | X | J | XJ62 | 1710 | J | 17 | X | IN | LND | 1710 | URMA |  |  |  |  |  | 2DC8480 |  |  |  |  |  |  |  |  |  |
| XJ801710 |  | CA17 ExtrBldgFl1 - Inspections/ Mech. Acceptance/ Loop Checks | 85d | 2012-09-20 | 2012-12-15 | XJ621710 FS-60d, X3J120 FF, EJ801710 (other project), XE601710 FF, XJ701710 FF+10d, XJ391710 FF+10d, X030410030, XJ641710 FS-60d, XJ8017115, XJ8017115 (other project) |  |  |  | -116.5d | 0d | TB26 - 3 - Construction Normal 7days * CA17 | Loop Checks [640 pcs]; Loop checks [3200 h] | 128,000 |  | 3200,00 | 2011-06-10 | 2012-04-30 | E-17-02-01 | 2012-08-18 | 2012-03-01 | XJ801710 | 3200 | 0 |  | XE60, XJ39, XJ62, XJ64, XJ70 | UDF_G1 | 934 | 17 | 200 | 200 | C | LND | X | J | XJ80 | 1710 | J | 17 | X | LT | LND | 1710 | URMA |  |  |  |  |  | 2DC8480 | 2012-08-18 |  |  |  |  |  |  |  |  |
|  | S | **Safety & Environment** |  | 2011-11-23 | 2012-01-18 |  |  |  |  |  |  |  |  |  |  |  |  |  |  |  |  |  |  |  |  |  |  |  |  |  |  |  |  |  |  |  |  |  |  |  |  |  |  |  |  |  |  |  |  |  |  |  |  |  |  |  |  |  |  |
| XS401710 |  | CA17 ExtrBldgFl1 - Noise Protection Ceiling | 50d | 2011-11-23 | 2012-01-18 | XC601710 FS-20d |  |  |  | 431.5d | 14d | TB26 - 3 - Construction Normal 7days * CA17 |  |  |  |  |  |  |  |  |  | XS401710 | 0 | 0 |  |  |  | 934 | 17 | 200 | 200 | C | LND | X | S | XS40 | 1710 | S | 17 | X | EB | LND | 1710 |  |  |  |  |  |  |  |  |  |  |  |  |  |  |  |  |
|  | W | **Painting** |  | 2011-10-13 | 2012-03-10 |  |  |  |  |  |  |  |  |  |  |  |  |  |  |  |  |  |  |  |  |  |  |  |  |  |  |  |  |  |  |  |  |  |  |  |  |  |  |  |  |  |  |  |  |  |  |  |  |  |  |  |  |  |  |
| XW501710 |  | CA17 ExtrBldgFl1 - Surf.Protection Piping | 120d | 2011-10-13 | 2012-03-10 | XR201710 SS+25d, XR801700 FF+10d |  |  |  | 95d | 78d |  | Piping painting [2113 sqm]; Piping painting [5283 h] | 3,841.78 |  | 5283,00 |  |  |  |  |  | XW501710 | 5283 | 0 |  |  |  | 934 | 17 | 200 | 200 | C | LND | X | W | XW50 | 1710 | W | 17 | X | PA | LND | 1710 |  |  |  |  |  |  |  |  | OMUS-1 |  |  |  |  |  |  |  |
|  | V | **Insulation** |  | 2012-03-05 | 2012-06-26 |  |  |  |  |  |  |  |  |  |  |  |  |  |  |  |  |  |  |  |  |  |  |  |  |  |  |  |  |  |  |  |  |  |  |  |  |  |  |  |  |  |  |  |  |  |  |  |  |  |  |  |  |  |  |
| XV301710 |  | CA17 ExtrBldgFl1 - Insulation Equipment | 100d | 2012-03-05 | 2012-06-16 | IMS-C-000210 FF, XE801710 SS+20d |  |  |  | 19d | 0d | TB26 - 3 - Construction Normal 7days * CA17 | Equipment insulation [700 sqm]; Equipment insulation [8750 h] | 2,736.1 |  | 8750,00 |  | 2012-03-30 | E-13-03 |  |  | XV301710 | 8750 | 0 |  |  |  | 934 | 17 | 200 | 200 | C | LND | X | V | XV30 | 1710 | V | 17 | X | INS | LND | 1710 |  |  |  |  |  |  | 2DC8480 |  | OMUS-1 |  |  |  |  |  |  |  |
| XV501710 |  | CA17 ExtrBldgFl1 - Insulation Piping | 100d | 2012-03-16 | 2012-06-26 | XV301710 FF+10d, XR601710 SS+10d, IMS-C-000210 FF, XE801710 FF+20d |  |  |  | 19d | 135.5d | TB26 - 3 - Construction Normal 7days * CA17 | Piping insulation [1800 sqm]; Piping insulation [13500 h] | 10,950.33 |  | 13500,00 |  | 2012-04-30 | E-13-01 |  |  | XV501710 | 13500 | 0 |  |  |  | 934 | 17 | 200 | 200 | C | LND | X | V | XV50 | 1710 | V | 17 | X | INS | LND | 1710 |  |  |  |  |  |  | 2DC8480 |  | OMUS-1 |  |  |  |  |  |  |  |
|  | 11 | **CA17 - Extrusion Structure** |  |  |  |  |  |  |  |  |  |  |  |  |  |  |  |  |  |  |  |  |  |  |  |  |  |  |  |  |  |  |  |  |  |  |  |  |  |  |  |  |  |  |  |  |  |  |  |  |  |  |  |  |  |  |  |  |  |
|  | 18 | **CA17 - Extrusion Bldg 2nd Floor +12,75m** |  | 2011-02-01 | 2012-10-19 |  |  |  |  |  |  |  |  |  |  |  |  |  |  |  |  |  |  |  |  |  |  |  |  |  |  |  |  |  |  |  |  |  |  |  |  |  |  |  |  |  |  |  |  |  |  |  |  |  |  |  |  |  |  |
|  | C | **Civil Work** |  | 2011-05-10 | 2012-02-15 |  |  |  |  |  |  |  |  |  |  |  |  |  |  |  |  |  |  |  |  |  |  |  |  |  |  |  |  |  |  |  |  |  |  |  |  |  |  |  |  |  |  |  |  |  |  |  |  |  |  |  |  |  |  |
| XC40171805 |  | CA17 ExtrBldgFl2 - Precast Concrete Elements Stairtower <18m North/South | 30d | 2011-05-10 A | 2011-06-11 A | EC48171810 (other project), P3C02D2 (other project) | 100% | 2011-05-10 | 2011-06-08 |  |  | TB26 - 3 - Construction Normal 7days * CA17 |  |  |  |  |  |  |  |  |  | XC40171805 | 0 | 0 |  |  |  | 934 | 17 | 200 | 200 | C | MO04 | X | C | XC40 | 1718 | C | 17 | X | pre | LND | 1718 | MO11 |  |  |  |  | x |  |  |  | CA17 - critical - CW5 |  |  |  |  |  |  |
| XC40171810 |  | CA17 ExtrBldgFl2 - Concrete Works Col/Walls <18m (A-F/1-5) | 132d | 2011-06-22 A | 2011-08-25 A | EC48171810 (other project) FS+10d, XC40171020 FS+4d, XC40171010 | 100% | 2011-06-22 | 2011-10-31 |  |  | TB26 - 3 - Construction Normal 7days * CA17 | Concrete works [1000 cbm]; Concrete works [30000 h] | 23,503 |  | 30000,00 |  |  |  |  |  | XC40171810 | 30000 | 9000 |  |  |  | 934 | 17 | 200 | 200 | C | MO04 | X | C | XC40 | 1718 | C | 17 | X | EB | LND | 1718 | MO11 |  |  |  |  | x |  |  | MTA | CA17 - critical - CW5 | x | UDF_G4 | 27.8. | x | C9-1 |  |
| XC40171815 |  | CA17 ExtrBldgFl2 - Erection Precast Elements Stairtower <18m North/South | 10d | 2011-07-30 A | 2011-08-20 A | XC40171810, XC40171805 FF+5d | 100% | 2011-09-18 | 2011-09-27 |  |  | TB26 - 3 - Construction Normal 7days * CA17 | Precast Concrete Works [60 cbm]; Precast concrete works [150 h] | 6,000 | 1,894.74 | 150,00 |  |  |  |  |  | XC40171815 | 150 | 0 |  |  |  | 934 | 17 | 200 | 200 | C | MO04 | X | C | XC40 | 1718 | C | 17 | X | EB | LND | 1718 | MO11 |  |  |  |  | x |  |  | MTA | CA17 - critical - CW5 |  |  | 27.8. |  | C9-1 |  |
| XC40171820 |  | CA17 ExtrBldgFl2 - Concrete Works Ceiling +18m | 11d | 2011-08-15 A | 2011-08-25 A | EC48171820 (other project), XN201718, XC40171810 SS+20d | 100% |  |  |  |  | TB26 - 3 - Construction Normal 7days * CA17 | Concrete works [630 cbm]; Concrete works [18900 h] | 13,924.42 |  | 18900,00 |  |  |  |  |  | XC40171820 | 18900 | 0 |  |  |  | 934 | 17 | 200 | 200 | C | MO04 | X | C | XC40 | 1718 | C | 17 | X | EB | LND | 1718 | MO11 |  |  |  |  |  |  |  | MTA | CA17 - critical - CW5 |  |  | 27.8. |  | C9-1 |  |
| XC501718 |  | CA17 ExtrBldgFl2 - Finishing Works Rooms | 120d | 2011-10-11 | 2012-02-15 | XC001718 FF, XC510C00 FS+15d, P3S06S (other project) FF+20d, IMS-C-000080 FF, EC501710 (other project) FS+20d, XC40171820, P3S09S (other project) FF+10d |  |  |  | 81d | 0d | TB26 - 3 - Construction Normal 7days * CA17 | Finishing Works - Extrusion Building CA17 [33593 mhr]; Finishing Works - Extrusion building CA17 [33593 h] | 3,359,300 |  | 33593,00 |  |  |  |  |  | XC501718 | 33593 | 0 |  |  |  | 934 | 17 | 200 | 200 | C | CiC | X | C | XC50 | 1718 | C | 17 | X | EB | LND | 1710 |  |  |  |  |  |  |  |  | XC50 |  |  |  |  |  |  | 1 |
| XC501718_1 |  | CA17 ExtrBldgFl2 - Plastering and Painting | 20d | 2011-10-11 | 2011-10-30 | XC501718 SS |  |  |  | 101d | 0d | TB26 - 3 - Construction Normal 7days * CA17 |  |  |  | 33593,00 |  |  |  |  |  | XC501718 | 33593 | 0 |  |  |  | 934 | 17 | 200 | 200 | C | CiC | X | C | XC50 | 1718 | C | 17 | X | EB | LND | 1710 |  |  |  |  |  |  |  |  |  |  |  |  |  |  |  | 1 |
| XC40171813 |  | CA17 ExtrBldgFl2 - Concrete Works Stairtower (G-H/1-6) | 15d | 2011-12-01 | 2011-12-15 | XC40171810, XC40171013 |  |  |  | -161d | 0d | TB26 - 3 - Construction Normal 7days * CA17 | Concrete works [230 cbm]; Concrete works [6900 h] | 23,503 |  | 6900,00 |  |  |  |  |  | XC40171813 | 6900 | 0 |  |  |  | 934 | 17 | 200 | 200 | C | MO04 | X | C | XC40 | 1718 | C | 17 | X | EB | LND | 1718 | MO11 |  |  |  |  | x |  |  | MTA | CA17 - critical - CW5 |  |  |  |  | C9-1 |  |

Notes:
- XW501710: P3 Activity Log Info: Clarification Surface Protection during / Prefab
- XC40171810: Current Status: 05.02.2011 (O. Siegel): Angaben von MO11 (04.02.2011), dass der frьheste / Starttermin 01-Apr-11 ist. / 12.01.2011 (Oxana): im Progress Measurement Report wurde die CA17 nicht in / Ebenen aufgeteilt (die Ebenen sind mit dem gleichen Anteilsfaktor gewichtet), / d.h. bei einigen Aktivitдten kann ein "Progress" stehen, jedoch es handelt sich / um einen Progress im gesamten Gebдude, nicht fьr die ausgewiesene Ebene.
- XC40171813: Current Status: 05.02.2011 (O. Siegel): Angaben von MO11 (04.02.2011), dass der frьheste / Starttermin 01-Apr-11 ist. / 12.01.2011 (Oxana): im Progress Measurement Report wurde die CA17 nicht in / Ebenen aufgeteilt (die Ebenen sind mit dem gleichen Anteilsfaktor gewichtet), / d.h. bei einigen Aktivitдten kann ein "Progress" stehen, jedoch es handelt sich / um einen Progress im gesamten Gebдude, nicht fьr die ausgewiesene Ebene.

| ID | WBS | Activity | Type | Duration | Start | Finish | Predecessors | Complete | Remaining | Planned start | Planned finish | Total float | Free float | Constraint | Calendar | Resources | Cost | Actual cost | TB26 Ressource Budget | UDF_SAVE ACT ID | UDF_CHECK BASELINE | UDF_BUDGETED LABOR UNIT | UDF_ACTUAL LABOR UNIT | Department | Type of Work | Constr. Area | PMT-Area | PMT-Schedule Org | PMT-Phase | PMT-Respons. | Zeigen/n. Zeigen | WBS Phase | WBS Discipline | WBS Type of Work | WBS Objects | Russia WBS Discipline (Russia) | Russia Construction Area | Russia WBS Phase | IMS | UPT | Russia WBS Objects | UDF_Text4 | UDF_CONTRACT START DATE | UDF_CONTRACT FINISH DATE | UDF_CONTRACT ITEM | UDF_CONTRACT INDICATOR | TB26 Semantics | UDF_EXPECTED START | UDF_EXPECTED FINISH | UDF_SELECT UPDATE PROGRESS | Inquiry/Order No | Subcontractor | UDF_CHECK RESOURCE DATES | UDF_SELECT | UDF_L3 START DATE | UDF_L3 FINISH DATE | UDF_Weight (ton) | WEIGHT | UDF_TAG No | UDF_Object No | UDF_PACKAGE | UDF_LEVEL | POSITION |
| --- | --- | --- | --- | --- | --- | --- | --- | --- | --- | --- | --- | --- | --- | --- | --- | --- | --- | --- | --- | --- | --- | --- | --- | --- | --- | --- | --- | --- | --- | --- | --- | --- | --- | --- | --- | --- | --- | --- | --- | --- | --- | --- | --- | --- | --- | --- | --- | --- | --- | --- | --- | --- | --- | --- | --- | --- | --- | --- | --- | --- | --- | --- | --- |
|  | N | **Structural Steel** |  |  | 2011-02-01 | 2011-11-24 |  |  |  |  |  |  |  |  |  |  |  |  |  |  |  |  |  |  |  |  |  |  |  |  |  |  |  |  |  |  |  |  |  |  |  |  |  |  |  |  |  |  |  |  |  |  |  |  |  |  |  |  |  |  |  |  |  |
| XN701701 |  | CA17 ExtrBldgFl1 SK1701- KMD Assy Drawings Level 111m | milestone | 0d | 2011-02-01 A | 2011-02-01 A |  | 100% |  |  |  |  |  | finish on 2011-01-22 | TB26 - V - Construct-Winter partly * |  |  |  | 22t | XN701701 | x | 0 | 0 | 934 | XNK | 17 | 200 | 200 | C | LND | KMD | X | N | XN05 | 1718 | N | 17 | X | SS | LND | 1718 |  |  |  |  |  |  |  |  |  |  |  |  |  |  |  |  |  |  |  |  |  |  |
| XN711701 |  | CA17 ExtrBldgFl1 SK1701 - Steel Deliveries Level 111m | milestone | 0d | 2011-03-01 A | 2011-03-01 A |  | 100% |  |  |  |  |  | finish on 2011-02-28 | TB26 - 3 - Construction Normal 7days * CA17 |  |  |  | 22t | XN711701 |  | 0 | 0 | 934 | XNK | 17 | 200 | 200 | C | LND | SD | X | N | XN06 | 1718 | N | 17 | X | SS | LND | 1718 |  |  |  |  |  |  |  |  |  |  |  |  |  |  |  |  |  |  |  |  |  |  |
| XN201718 |  | CA17 ExtrBldgFl2 SK1701- Erec Prim Steel+M.Sheets <18m |  | 115d | 2011-04-21 A | 2011-08-16 A | XN100C00, XC40171020, XC40171815, XC40171015, XC40171810, P3N022N (other project), XC40171026 FF, XC40171805, XC40171815 FF | 100% |  |  |  |  |  | start on or after 2011-06-13 | TB26 - 3 - Construction Normal 7days * CA17 | Piperacks, Main Structures [767 t]; Piperacks, Main structures [32597.5 h] | 4,966.67 |  | 32597,50 | XN201718 |  | 32597,5 | 3570 | 934 | PU10 | 17 | 200 | 200 | C | LND | C9-1 | X | N | XN20 | 1718 | N | 17 | X | SS | LND | 1718 | CA17 - critical - CW5 | 2011-02-01 | 2011-03-20 | E-04-13 | UDF_G4 | t | 2011-04-21 | 2011-08-08 | 27.8. | 2DC8990 | ChSK |  |  |  |  |  |  |  |  |  |  |  |
| XN301718 |  | CA17 ExtrBldgFl2 SK1701 - Install Eqpt Platforms |  | 40d | 2011-08-07 A | 2011-09-15 | P3N022N (other project), XN201718 FS-10d |  | 20d |  |  | 143d | 0d |  | TB26 - 3 - Construction Normal 7days * CA17 | Ladders & platforms [24 t]; Ladders & platforms [2400 h] | 1,123.41 |  | 2400,00 | XN301718 |  | 2400 | 0 | 934 | XNK | 17 | 200 | 200 | C | LND |  | X | N | XN30 | 1718 | N | 17 | X | SS | LND | 1718 |  |  |  |  | UDF_G4 | t | 2011-07-10 | 2011-08-08 | 27.8. |  | ChSK | x |  |  |  |  |  |  |  |  |  |  |
| XC701718 |  | CA17 ExtrBldgFl2 SK1701 - Install Supports Ceiling <18m |  | 30d | 2011-08-08 A | 2011-08-26 A | P3N022N (other project), XC40171820 | 100% |  | 2011-08-26 | 2011-09-24 |  |  |  | TB26 - 3 - Construction Normal 7days * CA17 | Piperacks, Main Structures [36 t]; Piperacks, Main structures [1530 h] |  |  | 1530,00 | XC701718 |  | 1530 | 0 | 934 | XNK | 17 | 200 | 200 | C | LND |  | X | C | XN70 | 1718 | N | 17 | X | SS | LND | 1718 |  |  |  |  |  |  |  |  |  |  | MO11 |  |  |  |  |  |  |  |  |  |  |  |
| XN801718 |  | CA17 ExtrBldgFl2 SK1701 - Install Cladding |  | 70d | 2011-09-15 | 2011-11-24 | XN201718, P3N02§N (other project), EN801711 (other project), P3N03N (other project) |  |  |  |  | 57d | 56d | start on or after 2011-09-15 | TB26 - 3 - Construction Normal 7days * CA17 | Cladding [1380 sqm]; Cladding [6900 h] | 2,266.04 |  | 6900,00 | XN801718 |  | 6900 | 0 | 934 | XNK | 17 | 200 | 200 | C | LND |  | X | N | XN80 | 1718 | N | 17 | X | SS | LND | 1718 |  |  |  |  | UDF_G4 |  |  |  |  |  | ChSK |  |  |  |  |  |  |  |  |  |  |  |
| XN401718 |  | CA17 ExtrBldgFl2 SK1701 - Install Railings,Ladders,etc. |  | 28d | 2011-09-16 | 2011-10-13 | XN201718 FS+30d, EC701710 (other project), XN301718 FF+8d |  |  |  |  | 223d | 0d |  | TB26 - 3 - Construction Normal 7days * CA17 | Ladders & platforms | 155.21 |  | 0,00 | XN401718 |  | 0 | 0 | 934 | XNK | 17 | 200 | 200 | C | LND |  | X | N | XN40 | 1718 | N | 17 | X | SS | LND | 1718 |  |  |  |  | UDF_G4 |  |  |  | 27.8. |  | ChSK | x |  |  |  |  |  |  |  |  |  |  |
| XN601718 |  | CA17 ExtrBldgFl2 SK1701 - Install Gratings |  | 33d | 2011-09-16 | 2011-10-18 | XN401718 FF+5d, PN691718 (other project) |  |  |  |  | 223d | 54d |  | TB26 - 3 - Construction Normal 7days * CA17 | Grating [300 sqm]; Grating [1125 h] | 8,639.94 |  | 1125,00 | XN601718 |  | 1125 | 0 | 934 | XNK | 17 | 200 | 200 | C | LND |  | X | N | XN60 | 1718 | N | 17 | X | SS | LND | 1718 |  |  |  |  | UDF_G4 |  |  |  | 27.8. |  | ChSK | x |  |  |  |  |  |  |  |  |  |  |
|  | H | **HVAC** |  |  | 2011-10-31 | 2012-06-07 |  |  |  |  |  |  |  |  |  |  |  |  |  |  |  |  |  |  |  |  |  |  |  |  |  |  |  |  |  |  |  |  |  |  |  |  |  |  |  |  |  |  |  |  |  |  |  |  |  |  |  |  |  |  |  |  |  |
| XH00171805 |  | CA17 ExtrBldgFl2 - Installation HVAC |  | 100d | 2011-10-31 | 2012-02-15 | XC40171026, XC701718 FF+10d, XN801718 FF+20d, P3H01SJ (other project), XH000000 FF, EH30171805 (other project), XC501718_1 |  |  |  |  | 101d | 0d | start on or after 2011-09-26 | TB26 - 3 - Construction Normal 7days * CA17 | HVAC - Extrusion Building CA17 [10282 mhr]; HVAC - Extrusion building CA17 [10282 h] |  |  | 10282,00 | XH00171805 |  | 10282 | 0 | 934 | XBB | 17 | 200 | 200 | C | LND |  | X | H | XH00 | 1700 | H | 17 | X | hvac | LND | 1718 |  | 2011-04-30 | 2011-07-31 |  |  |  |  |  |  |  | ARMO |  | REL XC50 | 2011-05-06 | 2011-08-01 |  |  |  |  |  |  |  |
| XH00172005 |  | CA17 ExtrBldgFl3 - Installation HVAC |  | 100d | 2011-11-25 | 2012-03-12 | XH000000 FF, XC501720 SS, XN801720 FF+20d, EH30172005 (other project), P3H01SK (other project), XC701720 SS+10d, XC501720_1 |  |  |  |  | 67d | 0d |  | TB26 - 3 - Construction Normal 7days * CA17 | HVAC - Extrusion Building CA17 [10283 mhr]; HVAC - Extrusion building CA17 [10283 h] |  |  | 10283,00 | XH00172005 |  | 10283 | 0 | 934 | XBB | 17 | 200 | 200 | C | LND |  | X | H | XH00 | 1700 | H | 17 | X | hvac | LND | 1720 |  | 2011-06-30 | 2011-09-30 |  |  |  |  |  |  |  | ARMO |  | REL XC50 | 2011-06-23 | 2011-09-12 |  |  |  |  |  |  |  |
| XH00171806 |  | CA17 ExtrBldgFl2 - Installation HVAC finished | milestone | 0d | 2012-02-15 | 2012-02-15 | XH00171805 FF |  |  |  |  | 101d | 7d |  | TB26 - 3 - Construction Normal 7days * CA17 |  |  |  |  | XH00171806 |  | 0 | 0 | 934 | XBB | 17 | 200 | 200 | C | LND |  | X | H | XH00 | 1718 | H | 17 | X | hvac | LND | 1718 |  | 2011-07-31 | 2011-07-31 | CM08 |  |  |  |  |  |  | ARMO |  |  | 2011-08-01 | 2011-08-01 |  |  |  |  |  |  |  |
| XH00171810 |  | CA17 ExtrBldgFl2 - Testing/Commissiong HVAC (Start w. temp. Power) |  | 85d | 2012-02-24 | 2012-05-21 | X0300008 FS+20d, P3H01SJ (other project), XH00171806, XH00171805, XH000C10, X0300080 |  |  |  |  | 94d | 0d |  | TB26 - 3 - Construction Normal 7days * CA17 |  |  |  |  | XH00171810 |  | 0 | 0 | 934 | XBB | 17 | 200 | 200 | C | LND |  | X | H | XH20 | 1718 | H | 17 | X | hvac | LND | 1718 |  | 2011-07-20 | 2011-10-20 |  |  |  |  |  |  |  | ARMO |  |  | 2011-08-01 | 2011-10-09 |  |  |  |  |  |  |  |
| XH00171807 |  | CA17 ExtrBldgFl2 - HVAC ready for Heating | milestone | 0d | 2012-03-05 | 2012-03-05 | XH00171810 SS+10d |  |  |  |  | 386.5d | 169.5d |  | TB26 - 3 - Construction Normal 7days * CA17 |  |  |  |  | XH00171807 |  | 0 | 0 | 934 | XBB | 17 | 200 | 200 | C | LND |  | X | H | XH00 | 1718 | H | 17 | X | hvac | LND | 1718 |  |  |  | CM08 |  |  |  |  |  |  | ARMO |  |  | 2011-08-11 | 2011-08-11 |  |  |  |  |  |  |  |
| XH00172010 |  | CA17 ExtrBldgFl3 - Testing/Commissiong HVAC (Start w. temp. Power) |  | 85d | 2012-03-13 | 2012-06-07 | X0300008 FS+20d, XH00172005, XH000C10 |  |  |  |  | 77d | 0d |  | TB26 - 3 - Construction Normal 7days * CA17 |  |  |  |  | XH00172010 |  | 0 | 0 | 934 | XBB | 17 | 200 | 200 | C | LND |  | X | H | XH20 | 1720 | H | 17 | X | hvac | LND | 1720 |  | 2011-09-20 | 2011-12-10 |  |  |  |  |  |  |  | ARMO |  |  | 2011-09-12 | 2011-11-21 |  |  |  |  |  |  |  |
| XH00172007 |  | CA17 ExtrBldgFl3 - HVAC ready for Heating | milestone | 0d | 2012-03-23 | 2012-03-23 | XH00172010 SS+10d |  |  |  |  | 369.5d | 157.5d |  | TB26 - 3 - Construction Normal 7days * CA17 |  |  |  | 4113 | XH00172007 |  | 0 | 0 | 934 | XBB | 17 | 200 | 200 | C | LND |  | X | H | XH00 | 1720 | H | 17 | X | hvac | LND | 1720 |  |  |  |  |  |  |  |  |  |  | ARMO |  |  | 2011-09-22 |  |  |  |  |  |  |  |  |
|  | U | **Package Units** |  |  |  |  |  |  |  |  |  |  |  |  |  |  |  |  |  |  |  |  |  |  |  |  |  |  |  |  |  |  |  |  |  |  |  |  |  |  |  |  |  |  |  |  |  |  |  |  |  |  |  |  |  |  |  |  |  |  |  |  |  |
|  | B | **Mechanical - Stationary Equipment** |  |  | 2011-08-26 | 2012-06-25 |  |  |  |  |  |  |  |  |  |  |  |  |  |  |  |  |  |  |  |  |  |  |  |  |  |  |  |  |  |  |  |  |  |  |  |  |  |  |  |  |  |  |  |  |  |  |  |  |  |  |  |  |  |  |  |  |  |
| XB001718 |  | CA17 ExtrBldgFl2 - Install Static Eqpt | level of effort | 190.88d | 2011-08-26 A | 2012-06-25 | RF-21441 SS, RF-22431 FF, RF-22441 SS, RF-22441 FF, BL-21402A/B SS, RF-21424 SS, RF-21422 FF, RF-22423 FF, RF-22432 SS, RF-21427 FF, RF-22421 FF, RF-21431 FF, RF-22424 SS, RF-21422 SS, BL-22402 FF, RF-21431 SS, RF-22432 FF, RF-22425 SS, RF-22425 FF, RF-22422 SS, RF-21421 SS, V-23702A/B FF, RF-21436 SS, RF-21436 FF, BL-21402A/B FF, RF-21428 SS, RF-21421 FF, RF-21427 SS, RF-21432 FF, RF-21432 SS, RF-21441 FF, RF-22422 FF, RF-21428 FF, RF-21423 FF, RF-21423 SS, BL-22402 SS, RF-22424 FF, RF-21425 FF, RF-21425 SS, RF-22421 SS, RF-21424 FF, V-23702A/B SS, RF-22423 SS, RF-22431 SS, RF-22427 SS, RF-22427 FF, XX-21402 SS, XX-21402 FF |  | 290.5d | 2011-08-26 | 2012-03-13 | 278d | 0d |  | TB26 - 3 - Construction Normal 7days * CA17 |  |  |  | 26 | XB001718 |  | 0 | 0 | 934 | PU10 | 17 | 200 | 200 | C | LND |  | X | B | XB00 | 1718 | B | 17 | X | EQ | LND | 1718 |  | 2011-05-20 | 2011-07-20 | E-08-01-13 |  |  |  |  |  | 2DC8990 |  |  | OMUS-1 |  |  |  |  |  |  |  |  |  |
| XX-21501 |  | ELUTIATOR (Pellet cleaning and Dedusting System) |  | 18.75d | 2011-08-26 A | 2011-09-16 | XC40171820, P3U10S1D (other project), P3U10S2A (other project) | 5% | 17.75d |  |  | 202.25d | 120.25d |  |  | Static Equipment < 10 tons [1.35 t]; Static equipment < 10t [135 h] | 5,400 | 284.21 | 135,00 | XX-21501 |  | 135 | 0 |  |  | 31 |  |  |  |  | EQ | X | B |  | 3110 |  |  |  |  |  |  |  |  |  |  |  |  |  |  |  |  | OMUS-1 |  |  |  |  | 1,35 | 1350 | XX-21501 | SK1718 | PU10 CONVEYING SYSTEM (PK-21501) ZEPPELIN |  |  |
|  | M | **Mechanical - Rotating Equipment** |  |  | 2011-08-26 | 2012-03-07 |  |  |  |  |  |  |  |  |  |  |  |  |  |  |  |  |  |  |  |  |  |  |  |  |  |  |  |  |  |  |  |  |  |  |  |  |  |  |  |  |  |  |  |  |  |  |  |  |  |  |  |  |  |  |  |  |  |
| DV-22501-35 |  | DIVERTER VALVES (36 items) |  | 20d | 2011-08-26 A | 2011-09-17 | XC40171820, P3U10S1D (other project), P3U10S2A (other project), ER291700 (other project) | 5% | 19d |  |  | 201d | 119d |  |  | Static equipment < 10t [26 h]; Static Equipment < 10 tons [0.26 t] | 1,040 | 52 | 925,50 | DV-22501-35 | diff name in cb | 26 | 0 |  |  | 31 |  |  |  |  | EQ | X | B |  | 3110 |  |  |  |  |  |  |  |  |  |  |  |  |  |  |  |  | OMUS-1 |  |  |  |  | 0,257 | 500 | DV-22501-35 | SK1718 | PU10 CONVEYING SYSTEM (PK-21501) ZEPPELIN | elev +43.00 |  |
| RF-21431 |  | CONVEYING SCREW |  | 15d | 2011-08-26 A | 2011-09-12 | P3U02S4 (other project), XC40171820, XN201718 | 7% | 14d |  |  | 119d | 3d |  |  | Static Equipment < 10 tons [2.8 t]; Static equipment < 10t [280 h] | 11,200 | 746.67 | 280,00 | RF-21431 |  | 280 | 0 |  |  | 17 |  |  |  |  | EQ | X | B |  | 1718 |  |  |  |  |  |  |  |  |  |  |  |  |  |  |  |  |  |  |  |  |  | 2,8 | 2800 | RF-21431 | SK1718 | PU02 ADDITIVE SYSTEM COMPONENTS (PK-21-/22401) | structure +14.30 | a |
| RF-21432 |  | CONVEYING SCREW |  | 15d | 2011-08-26 A | 2011-09-12 | XN201718, XC40171820, P3U02S4 (other project) | 7% | 14d |  |  | 119d | 3d |  |  | Static Equipment < 10 tons [2.8 t]; Static equipment < 10t [280 h] | 11,200 | 746.67 | 280,00 | RF-21432 |  | 280 | 0 |  |  | 17 |  |  |  |  | EQ | X | B |  | 1718 |  |  |  |  |  |  |  |  |  |  |  |  |  |  |  |  |  |  |  |  |  | 2,8 | 2800 | RF-21432 | SK1718 | PU02 ADDITIVE SYSTEM COMPONENTS (PK-21-/22401) | concrete +12.850 | a |
| RF-21441 |  | PREBLEND PELLETS FEEDER |  | 5d | 2011-08-26 A | 2011-08-31 | P3U10S1D (other project), XC40171820, XN301718 SS+10d, XC40171820 FF | 20% | 4d |  |  | 139d | 129d |  |  | Static Equipment < 10 tons [0.5 t]; Static equipment < 10t [50 h] | 2,000 | 400 | 50,00 | RF-21441 |  | 50 | 0 |  |  | 17 |  |  |  |  | EQ | X | B |  | 1718 |  |  |  |  |  |  |  |  |  |  |  |  |  |  |  |  |  |  |  |  |  | 0,5 | 500 | RF-21441 | SK1718 | PU10 CONVEYING SYSTEM (PK-21501) ZEPPELIN | concrete +12.900 | a |
| RF-22431 |  | CONVEYING SCREW |  | 15d | 2011-08-26 A | 2011-09-12 | P3U02S4 (other project), XN201718, XC40171820 | 7% | 14d |  |  | 119d | 3d |  |  | Static Equipment < 10 tons [2.8 t]; Static equipment < 10t [280 h] | 11,200 | 746.67 | 280,00 | RF-22431 |  | 280 | 0 |  |  | 17 |  |  |  |  | EQ | X | B |  | 1718 |  |  |  |  |  |  |  |  |  |  |  |  |  |  |  |  |  |  |  |  |  | 2,8 | 2800 | RF-22431 | SK1718 | PU02 ADDITIVE SYSTEM COMPONENTS (PK-21-/22401) | structure +14.30 | a |
| RF-22432 |  | CONVEYING SCREW |  | 15d | 2011-08-26 A | 2011-09-12 | XN201718, P3U02S4 (other project), XC40171820 | 7% | 14d |  |  | 119d | 3d |  |  | Static Equipment < 10 tons [2.8 t]; Static equipment < 10t [280 h] | 11,200 | 746.67 | 280,00 | RF-22432 |  | 280 | 0 |  |  | 17 |  |  |  |  | EQ | X | B |  | 1718 |  |  |  |  |  |  |  |  |  |  |  |  |  |  |  |  |  |  |  |  |  | 2,8 | 2800 | RF-22432 | SK1718 | PU02 ADDITIVE SYSTEM COMPONENTS (PK-21-/22401) | concrete +12.850 | a |
| RF-22441 |  | PREBLEND PELLETS FEEDER |  | 5d | 2011-08-26 A | 2011-08-31 | XC40171820 FF, XN301718 SS+10d, P3U10S2A (other project), XC40171820 | 20% | 4d |  |  | 139d | 129d |  |  | Static Equipment < 10 tons [0.5 t]; Static equipment < 10t [50 h] | 2,000 | 400 | 50,00 | RF-22441 |  | 50 | 0 |  |  | 17 |  |  |  |  | EQ | X | B |  | 1718 |  |  |  |  |  |  |  |  |  |  |  |  |  |  |  |  |  |  |  |  |  | 0,5 | 500 | RF-22441 | SK1718 | PU10 CONVEYING SYSTEM (PK-21501) ZEPPELIN | concrete +12.900 | a |
| XX-22501-RF01 |  | ELUTRIATOR AIR CYCLONE OUTLET ROTARY VALVE |  | 1.25d | 2011-09-07 | 2011-09-08 | P3U10S2A (other project), XC40171820, XX-21501 SS+10d, P3U10S1D (other project) |  |  |  |  | 209.75d | 127.75d |  |  | Static Equipment < 10 tons [0.12 t]; Static equipment < 10t [11.5 h] | 460 |  | 11,50 | XX-22501-RF01 |  | 11,5 | 0 |  |  | 31 |  |  |  |  | EQ | X | B |  | 3110 |  |  |  |  |  |  |  |  |  |  |  |  |  |  |  |  | OMUS-1 |  |  |  |  | 0,115 | 500 | XX-22501-RF01 | SK1718 | PU10 CONVEYING SYSTEM (PK-21501) ZEPPELIN |  |  |
| RF-21421 |  | ADDITIVE FEEDER |  | 15d | 2011-09-16 | 2011-10-03 | XN201718, P3U02S4 (other project), XC40171820, RF-21431, XN301718, RF-21432 |  |  |  |  | 131d | 121d |  |  | Static Equipment < 10 tons [0.17 t]; Static equipment < 10t [16.5 h] | 660 |  | 16,50 | RF-21421 |  | 16,5 | 0 |  |  | 17 |  |  |  |  | EQ | X | B |  | 1718 |  |  |  |  |  |  |  |  |  |  |  |  |  |  |  |  |  |  |  |  |  | 0,165 | 2800 | RF-21421 | SK1718 | PU02 ADDITIVE SYSTEM COMPONENTS (PK-21-/22401) | structure +17.125 | a |
| RF-21422 |  | ADDITIVE FEEDER |  | 15d | 2011-09-16 | 2011-10-03 | RF-21432, XN301718, XN201718, RF-21431, XC40171820, P3U02S4 (other project) |  |  |  |  | 131d | 121d |  |  | Static Equipment < 10 tons [0.17 t]; Static equipment < 10t [16.5 h] | 660 |  | 16,50 | RF-21422 |  | 16,5 | 0 |  |  | 17 |  |  |  |  | EQ | X | B |  | 1718 |  |  |  |  |  |  |  |  |  |  |  |  |  |  |  |  |  |  |  |  |  | 0,165 | 2800 | RF-21422 | SK1718 | PU02 ADDITIVE SYSTEM COMPONENTS (PK-21-/22401) | structure +17.125 | a |
| RF-21423 |  | ADDITIVE FEEDER |  | 15d | 2011-09-16 | 2011-10-03 | XN301718, RF-21431, XN201718, P3U02S4 (other project), XC40171820, RF-21432 |  |  |  |  | 131d | 121d |  |  | Static Equipment < 10 tons [0.17 t]; Static equipment < 10t [16.5 h] | 660 |  | 16,50 | RF-21423 |  | 16,5 | 0 |  |  | 17 |  |  |  |  | EQ | X | B |  | 1718 |  |  |  |  |  |  |  |  |  |  |  |  |  |  |  |  |  |  |  |  |  | 0,165 | 2800 | RF-21423 | SK1718 | PU02 ADDITIVE SYSTEM COMPONENTS (PK-21-/22401) | structure +17.125 | a |
| RF-21424 |  | PEROXIDE FEEDER |  | 15d | 2011-09-16 | 2011-10-03 | P3U02S4 (other project), RF-21432, XC40171820, XN301718, XN201718, RF-21431 |  |  |  |  | 131d | 121d |  |  | Static Equipment < 10 tons [0.17 t]; Static equipment < 10t [16.5 h] | 660 |  | 16,50 | RF-21424 |  | 16,5 | 0 |  |  | 17 |  |  |  |  | EQ | X | B |  | 1718 |  |  |  |  |  |  |  |  |  |  |  |  |  |  |  |  |  |  |  |  |  | 0,165 | 2800 | RF-21424 | SK1718 | PU02 ADDITIVE SYSTEM COMPONENTS (PK-21-/22401) | structure +17.125 | a |
| RF-21425 |  | ADDITIVE FEEDER |  | 15d | 2011-09-16 | 2011-10-03 | XC40171820, RF-21431, RF-21432, XN301718, XN201718, P3U02S4 (other project) |  |  |  |  | 131d | 121d |  |  | Static Equipment < 10 tons [0.17 t]; Static equipment < 10t [16.5 h] | 660 |  | 17,00 | RF-21425 |  | 16,5 | 0 |  |  | 17 |  |  |  |  | EQ | X | B |  | 1718 |  |  |  |  |  |  |  |  |  |  |  |  |  |  |  |  |  |  |  |  |  | 0,165 | 2800 | RF-21425 | SK1718 | PU02 ADDITIVE SYSTEM COMPONENTS (PK-21-/22401) | structure +17.125 | a |
| RF-21427 |  | ADDITIVE FEEDER |  | 15d | 2011-09-16 | 2011-10-03 | P3U02S4 (other project), XN201718, RF-21432, XC40171820, XN301718, RF-21431 |  |  |  |  | 131d | 121d |  |  | Static Equipment < 10 tons [0.3 t]; Static equipment < 10t [30 h] | 1,200 |  | 0,00 | RF-21427 |  | 30 | 0 |  |  | 17 |  |  |  |  | EQ | X | B |  | 1718 |  |  |  |  |  |  |  |  |  |  |  |  |  |  |  |  |  |  |  |  |  | 0,03 | 2800 | RF-21427 | SK1718 | PU02 ADDITIVE SYSTEM COMPONENTS (PK-21-/22401) | structure +17.125 | a |
| RF-21428 |  | TALC FEEDER |  | 15d | 2011-09-16 | 2011-10-03 | XC40171820, XN301718, XN201718, XC40171820 FF, RF-21432, P3U02S4 (other project), RF-21431 |  |  |  |  | 131d | 121d |  |  | Static Equipment < 10 tons [0.3 t]; Static equipment < 10t [30 h] | 1,200 |  | 10,00 | RF-21428 |  | 30 | 0 |  |  | 17 |  |  |  |  | EQ | X | B |  | 1718 |  |  |  |  |  |  |  |  |  |  |  |  |  |  |  |  |  |  |  |  |  | 0,03 | 2800 | RF-21428 | SK1718 | PU02 ADDITIVE SYSTEM COMPONENTS (PK-21-/22401) | structure +17.125 | a |
| RF-22421 |  | ADDITIVE FEEDER |  | 15d | 2011-09-16 | 2011-10-03 | XN301718, RF-22431, XN201718, RF-22432, XC40171820, P3U02S4 (other project) |  |  |  |  | 131d | 121d |  |  | Static Equipment < 10 tons [0.17 t]; Static equipment < 10t [16.5 h] | 660 |  | 16,50 | RF-22421 |  | 16,5 | 0 |  |  | 17 |  |  |  |  | EQ | X | B |  | 1718 |  |  |  |  |  |  |  |  |  |  |  |  |  |  |  |  |  |  |  |  |  | 0,165 | 2800 | RF-22421 | SK1718 | PU02 ADDITIVE SYSTEM COMPONENTS (PK-21-/22401) | structure +17.125 | a |
| RF-22422 |  | ADDITIVE FEEDER |  | 15d | 2011-09-16 | 2011-10-03 | XN301718, P3U02S4 (other project), XC40171820, RF-22432, RF-22431, ER291700 (other project), XN201718 |  |  |  |  | 131d | 121d |  |  | Static Equipment < 10 tons [0.17 t]; Static equipment < 10t [16.5 h] | 660 |  | 16,50 | RF-22422 |  | 16,5 | 0 |  |  | 17 |  |  |  |  | EQ | X | B |  | 1718 |  |  |  |  |  |  |  |  |  |  |  |  |  |  |  |  |  |  |  |  |  | 0,165 | 2800 | RF-22422 | SK1718 | PU02 ADDITIVE SYSTEM COMPONENTS (PK-21-/22401) | structure +17.125 | a |
| RF-22423 |  | ADDITIVE FEEDER |  | 15d | 2011-09-16 | 2011-10-03 | XN301718, XN201718, RF-22431, P3U02S4 (other project), RF-22432, XC40171820 |  |  |  |  | 131d | 121d |  |  | Static equipment < 10t [16.5 h]; Static Equipment < 10 tons [0.17 t] | 660 |  | 16,50 | RF-22423 |  | 16,5 | 0 |  |  | 17 |  |  |  |  | EQ | X | B |  | 1718 |  |  |  |  |  |  |  |  |  |  |  |  |  |  |  |  |  |  |  |  |  | 0,165 | 2800 | RF-22422 | SK1718 | PU02 ADDITIVE SYSTEM COMPONENTS (PK-21-/22401) | structure +17.125 | a |
| RF-22424 |  | PEROXIDE FEEDER |  | 15d | 2011-09-16 | 2011-10-03 | XN301718, XC40171820, RF-22431, P3U02S4 (other project), XN201718, RF-22432 |  |  |  |  | 131d | 121d |  |  | Static Equipment < 10 tons [0.17 t]; Static equipment < 10t [16.5 h] | 660 |  | 16,50 | RF-22424 |  | 16,5 | 0 |  |  | 17 |  |  |  |  | EQ | X | B |  | 1718 |  |  |  |  |  |  |  |  |  |  |  |  |  |  |  |  |  |  |  |  |  | 0,165 | 2800 | RF-22424 | SK1718 | PU02 ADDITIVE SYSTEM COMPONENTS (PK-21-/22401) | structure +17.125 | a |
| RF-22425 |  | ADDITIVE FEEDER |  | 15d | 2011-09-16 | 2011-10-03 | XN301718, RF-22431, P3U02S4 (other project), XN201718, XC40171820, RF-22432 |  |  |  |  | 131d | 116d |  |  | Static Equipment < 10 tons [0.17 t]; Static equipment < 10t [16.5 h] | 660 |  | 16,50 | RF-22425 |  | 16,5 | 0 |  |  | 17 |  |  |  |  | EQ | X | B |  | 1718 |  |  |  |  |  |  |  |  |  |  |  |  |  |  |  |  |  |  |  |  |  | 0,165 | 2800 | RF-22425 | SK1718 | PU02 ADDITIVE SYSTEM COMPONENTS (PK-21-/22401) | structure +17.125 | a |
| RF-22427 |  | ADDITIVE FEEDER |  | 15d | 2011-09-16 | 2011-10-03 | P3U02S4 (other project), XC40171820, XN201718, RF-22432, RF-22431, XN301718 |  |  |  |  | 131d | 116d |  |  | Static Equipment < 10 tons [0.3 t]; Static equipment < 10t [30 h] | 1,200 |  | 30,00 | RF-22427 |  | 30 | 0 |  |  | 17 |  |  |  |  | EQ | X | B |  | 1718 |  |  |  |  |  |  |  |  |  |  |  |  |  |  |  |  |  |  |  |  |  | 0,03 | 2800 | RF-22427 | SK1718 | PU02 ADDITIVE SYSTEM COMPONENTS (PK-21-/22401) | structure +17.125 | a |
| BL-21402A/B |  | FEEDERS VENT EXHAUST FAN |  | 10d | 2011-11-26 | 2011-12-07 | RF-21431, RF-22431, RF-21432, P3U02S4 (other project), RF-22432, EX-21401-MI01, XC40171820 |  |  |  |  | 56d | 0d |  |  | Static Equipment < 10 tons [0.8 t]; Static equipment < 10t [80 h] | 3,200 |  | 80,00 | BL-21402A/B |  | 80 | 0 |  |  | 17 |  |  |  |  | EQ | X | B |  | 1718 |  |  |  |  |  |  |  |  |  |  |  |  |  |  |  |  |  |  |  |  |  | 0,8 | 400 | BL-21402A/B | SK1718 | PU02 ADDITIVE SYSTEM COMPONENTS (PK-21-/22401) | concrete +12.90 (indoor) | a |
| BL-22402 |  | FEEDERS VENT EXHAUST FAN |  | 10d | 2011-12-01 | 2011-12-12 | BL-21402A/B SS, XC40171820, EX-21401-MI01, P3U02S4 (other project), EX-22401-MI01 |  |  |  |  | 52d | 0d |  |  | Static Equipment < 10 tons [0.8 t]; Static equipment < 10t [80 h] | 3,200 |  | 0,00 | BL-22402 | missing in CB | 80 | 0 |  |  | 17 |  |  |  |  | EQ | X | B |  | 1718 |  |  |  |  |  |  |  |  |  |  |  |  |  |  |  |  |  |  |  |  |  | 0,8 | 400 | BL-21402A/B | SK1718 | PU02 ADDITIVE SYSTEM COMPONENTS (PK-21-/22401) | concrete +12.90 (indoor) | a |
| XX-21402 |  | RETURN PELLET MASS FLOW METER |  | 10d | 2011-12-01 | 2011-12-12 | XC40171820, P3U02S4 (other project), BL-22402 SS, BL-21402A/B SS, RF-21436 SS |  |  |  |  | 58d | 0d |  |  | Static Equipment < 10 tons [0.21 t]; Static equipment < 10t [21 h] | 840 |  | 21,00 | XX-21402 |  | 21 | 0 |  |  | 17 |  |  |  |  | EQ | X | B |  | 1718 |  |  |  |  |  |  |  |  |  |  |  |  |  |  |  |  |  |  |  |  |  | 0,21 | 2800 | XX-21402 | SK1718 | PU02 ADDITIVE SYSTEM COMPONENTS (PK-21-/22401) | concrete +12.905 | a |
| V-23702A/B |  | BLADDER TANK |  | 10d | 2012-02-25 | 2012-03-07 | E-22502, RF-22431, RF-22425, K-22502 A/B, RF-22432, EX-22401, EX-22401-MI01, XC40171820, RF-22427 |  |  |  |  | 326.5d |  |  |  | Static Equipment < 10 tons; Static equipment < 10t |  |  | 0,00 | V-23702A/B | x | 0 | 0 |  |  | 17 |  |  |  |  | EQ | X | B |  | 1718 |  |  |  |  |  |  |  |  |  |  |  |  |  |  |  |  |  |  |  |  |  |  | 2800 | RF-22431 | SK1718 | PU02 ADDITIVE SYSTEM COMPONENTS (PK-21-/22401) | structure +12.90 | a |

Notes:
- XN711701: Scope: 09.02.2011: weight: 48 ton - Nov 47 ton; Dec 1 ton
- XN801718: Current Status: 2110806 Delivery end of September 2011 (Info from Fr. Schilka 02.08.2011)
- XH00171805: Current Status: 28.04.2011 (O.Siegel): Info von C.Wendel, dass die / Arbeiten erst ab 16-Juni-2011 anfangen kцnnen
- XH00171810: Current Status: 21.01.2011 - Siegel - Vorgдnger zur IBN HVAC / Condensat, LP-Dampf, Kьhlwasser von FF + 30 Tage Lag auf FS + 0 geдndert!
- XH00172010: Current Status: 21.01.2011 - Siegel - Vorgдnger zur IBN HVAC / Condensat, LP-Dampf, Kьhlwasser von FF + 30 Tage Lag auf FS + 0 geдndert!

| ID | WBS | Activity | Duration | Start | Finish | Predecessors | Total float | Free float | Constraint | Calendar | Resources | Cost | TB26 Ressource Budget | UDF_SELECT | UDF_SELECT UPDATE PROGRESS | UDF_SAVE ACT ID | UDF_BUDGETED LABOR UNIT | UDF_ACTUAL LABOR UNIT | UDF_COMMENTS_0827 | Department | Type of Work | Constr. Area | Inquiry/Order No | PMT-Area | PMT-Schedule Org | PMT-Phase | PMT-Respons. | WBS Phase | WBS Discipline | WBS Type of Work | WBS Objects | Russia WBS Discipline (Russia) | Russia Construction Area | Russia WBS Phase | IMS | UPT | Russia WBS Objects | UDF_CONTRACT START DATE | UDF_CONTRACT ITEM | UDF_PLANNED START | UDF_CONTRACT FINISH DATE | UDF_PLANNED FINISH | Subcontractor | UDF_CONTRACT FINISH DATE REV1 | UDF_CONTRACT START DATE REV1 | UDF_INDICATOR | TB26 Semantics | TB26 Material Res Values | UDF_ELECTRICAL START | UDF_ELECTRICAL FINISH | UDF_CHECK BASELINE | UDF_Vendor Representatives | UDF_PENALIZED FINISH |
| --- | --- | --- | --- | --- | --- | --- | --- | --- | --- | --- | --- | --- | --- | --- | --- | --- | --- | --- | --- | --- | --- | --- | --- | --- | --- | --- | --- | --- | --- | --- | --- | --- | --- | --- | --- | --- | --- | --- | --- | --- | --- | --- | --- | --- | --- | --- | --- | --- | --- | --- | --- | --- | --- |
|  | R | **Piping** |  | 2011-09-15 | 2012-04-11 |  |  |  |  |  |  |  |  |  |  |  |  |  |  |  |  |  |  |  |  |  |  |  |  |  |  |  |  |  |  |  |  |  |  |  |  |  |  |  |  |  |  |  |  |  |  |  |  |
| XR201718 |  | CA17 ExtrBldgFl2 - Piping Prefabrication | 110d | 2011-09-15 | 2012-01-10 | P3U10S1D (other project), ER49171805 (other project) SS+12d, ER491718 (other project) SS+12d, XR500C00 FS+15d | 12d | 0d | start on or after 2011-09-15 | TB26 - 3 - Construction Normal 7days * CA17 | A/G piping prefabrication [3120 Fpi]; Conveying S. piping prefabrication [200 Fpi]; A/G Piping (Prefab) [11700 h]; Conveying system (Prefab) [500 h] | 30,602.22 | 12200,00 | OMUS-1 | 27.8. | XR201718 | 12200 | 0 | Start mid of sept | 934 | PU10 | 17 | 2DC8990 | 200 | 200 | C | LND | X | R | XR20 | 1718 | R | 17 | X | PRP | LND | 1718 |  |  |  |  |  |  |  |  |  |  |  |  |  |  |  |  |
| XR401718 |  | CA17 ExtrBldgFl2 - Piping Installation | 90d | 2011-11-25 | 2012-03-01 | RF-21432 FF+20d, RF-22421 FF, RF-21423 FF, XR201718 FS-40d, XR201718 FF+10d, RF-22432 FF+20d, RF-21424 FF, RF-22427 FF, RF-21422 FF, RF-22423 FF, RF-21441 FF+20d, RF-22431 FF+20d, RF-22425 FF, RF-22424 FF, XX-21402 FF, IMS-C-000190 FF, P3S07S (other project) FF+20d, P3R09AS (other project) FF+20d, RF-21431 FF+20d, RF-21428 FF, RF-21427 FF, XN801718 FF-30d, RF-22441 FF+20d, BL-21402A/B FF+20d, RF-22422 FF, BL-22402 FF+20d, P3J02CS (other project), XC701718 SS+10d, RF-21421 FF, RF-21425 FF, RF-21436 FF | 12d | 0d |  | TB26 - 3 - Construction Normal 7days * CA17 | A/G piping field installation [3830 Fpi]; Conveying S. piping field installation [200 Fpi]; Control & Shut-off valves [32 pcs]; A/G Piping (Field) [23937.5 h]; Conveying system (Field) [1000 h]; Install Control & Shut-off Valves [168 h] | 74,413.49 | 25105,50 | OMUS-1 |  | XR401718 | 25105,5 | 0 |  | 934 | PU10 | 17 | 2DC8990 | 200 | 200 | C | LND | X | R | XR40 | 1718 | R | 17 | X | PI | LND | 1718 | 2011-02-25 | E-06-03-07 | 2011-05-12 |  |  |  |  |  |  |  |  |  |  |  |  |  |
| XR601718 |  | CA17 ExtrBldgFl2 - Piping Pressure Tests | 70d | 2012-01-21 | 2012-04-01 | XR401718 SS+50d, XR401718 FF+20d | 12d | 0d |  | TB26 - 3 - Construction Normal 7days * CA17 |  |  | 1241 | OMUS-1 |  | XR601718 | 0 | 0 |  | 934 |  | 17 |  | 200 | 200 | C | LND | X | R | XR60 | 1718 | R | 17 | X | HY | LND | 1718 |  | E-06-03-07 |  |  |  |  |  |  |  |  |  |  |  |  |  |  |
| XR801718 |  | CA17 ExtrBldgFl2 - Piping Reinstatement | 50d | 2012-02-20 | 2012-04-11 | IMS-C-000360 FF, XR601718 FF+10d | 12d | 0d |  | TB26 - 3 - Construction Normal 7days * CA17 |  |  | 620 | OMUS-1 |  | XR801718 | 0 | 0 |  | 934 |  | 17 |  | 200 | 200 | C | LND | X | R | XR80 | 1718 | R | 17 | X | PI | LND | 1718 |  | E-06-03-07 |  | 2012-02-25 | 2012-05-11 |  |  |  |  |  |  |  |  |  |  |  |
|  | E | **Electrical** |  | 2011-12-05 | 2012-08-24 |  |  |  |  |  |  |  |  |  |  |  |  |  |  |  |  |  |  |  |  |  |  |  |  |  |  |  |  |  |  |  |  |  |  |  |  |  |  |  |  |  |  |  |  |  |  |  |  |
| XC911718 |  | CA17 ExtrBldgFl2 - Install Earthing&Lightn.Sys_CIVIL | 40d | 2011-12-05 | 2012-01-20 | XC91171005 FF, XC40171820, EE901718 (other project) | 7d | 0d |  | TB26 - 3 - Construction Normal 7days * CA17 | Grounding & Lightning [240 pcs]; Grounding & Lightning [2700 h] | 108,000 | 2700,00 |  |  | XC911718 | 2700 | 0 |  | 934 |  | 17 |  | 200 | 200 | C | LND | X | C | XE91 | 1718 | C | 17 | X | EA | LND | 1718 | 2011-07-10 | E-16-07-08 |  | 2011-12-30 |  | MO11 |  |  |  |  |  |  |  |  |  |  |
| XE911719 |  | CA17 ExtrBldgFl2 - Install Earthing&Lightn.Sys_E/I | 20d | 2011-12-13 | 2012-01-08 | XN301718, XN601718, XB001718, XX-21402 | 169d | 280.5d |  | TB26 - 3 - Construction Normal 7days * CA17 |  |  | 265 |  |  | XE911719 | 0 | 0 |  | 934 |  | 17 |  | 200 | 200 | C | LND | X | E | XE91 | 1718 | E | 17 | X | EA | LND | 1718 | 2011-07-10 | E-16-07-08 |  | 2011-12-30 |  | URMA | 2012-07-10 | 2011-10-01 | UDF_G3 |  |  |  |  |  |  |  |
| XE401718 |  | CA17 ExtrBldgFl2 - Install Cable Trays | 40d | 2012-02-24 | 2012-04-04 | EE46171810 (other project), XN801718, XR401710 FS-80d, XB00171005, XM00171005 | -26d | 0d |  | TB26 - 3 - Construction Normal 7days * CA17 | Cable trays/conduits [1280 m]; Cable trays [3840 h] | 153,600 | 3840,00 |  |  | XE401718 | 3840 | 0 | after equipm. erection & 50% piping | 934 |  | 17 |  | 200 | 200 | C | LND | X | E | XE40 | 1718 | E | 17 | X | EL | LND | 1718 | 2011-06-10 | E-15-01-11 |  | 2011-11-30 |  | URMA | 2012-04-01 | 2011-09-20 | UDF_G2 | m | 3200 | 2011-09-07 | 2011-11-26 | x |  |  |
| XE801718 |  | CA17 ExtrBldgFl2 - Install Heat Tracing | 40d | 2012-03-02 | 2012-04-11 | E3E1950 (other project), XR401718 FS-45d, XR601718 FS-30d | 66d | 0d |  | TB26 - 3 - Construction Normal 7days * CA17 | Electrical Heat Tracing [900 m]; Electrical heat tracing [450 h] | 18,000 | 450,00 |  |  | XE801718 | 450 | 0 |  | 934 |  | 17 |  | 200 | 200 | C | LND | X | E | XE80 | 1718 | E | 17 | X | HT | LND | 1718 | 2011-06-20 | E-16-04-01 |  | 2012-03-20 |  | URMA | 2012-06-30 | 2011-09-15 | UDF_G3 |  |  |  |  |  | 005 |  |
| XE701718 |  | CA17 ExtrBldgFl2 - Install Lighting &Small Power | 50d | 2012-03-16 | 2012-05-05 | XE401718 SS+20d, XP341610 FS+50d, P3E09S (other project), EE761700 (other project), EE76510110 (other project) FF+20d, XH00171805 SS+20d, P3E03S2 (other project) FF+20d, EE76170010 (other project) FF+20d, XC501718 FS-40d | 54d | 165.5d |  | TB26 - 3 - Construction Normal 7days * CA17 | Lighting illuminates [150 pcs]; Lighting (iluminates) [1500 h] | 60,000 | 1500,00 |  |  | XE701718 | 1500 | 0 |  | 934 |  | 17 |  | 200 | 200 | C | LND | X | E | XE70 | 1718 | E | 16 | X | EL | LND | 1610 | 2011-05-10 | E-16-03-01 |  | 2012-01-31 |  | URMA | 2012-05-10 | 2011-08-15 | UDF_G2 |  |  |  |  |  |  |  |
| XE341718 |  | CA17 ExtrBldgFl2 - Install Local Operation Panels | 50d | 2012-03-26 | 2012-05-16 | EE46171810 (other project), XE401718 FS-10d, XR401718 FS-40d | 316.5d |  |  | TB26 - 3 - Construction Normal 7days * CA17 | Field Panels [11 pcs]; Field panels [220 h] | 8,800 | 220,00 |  |  | XE341718 | 220 | 0 | after equipm. erection & 50% piping | 934 |  | 17 |  | 200 | 200 | C | LND | X | E | XE34 | 1718 | E | 17 | X | EL | LND | 1718 | 2011-07-10 | E-16-07-08 |  | 2011-12-30 |  | URMA | 2012-07-10 | 2011-10-01 | UDF_G2 |  |  |  |  |  |  |  |
| XE50171810 |  | CA17 ExtrBldgFl2 - Cable Pulling Electric Part II (over SR1708) | 30d | 2012-06-15 | 2012-07-20 | XE500C01, XE401718 FF+10d, XE501708 SS+12d, EE561718 (other project) | -28.5d | 10d |  | TB26 - V - Construct-Winter partly * | Cable Pulling [12300 m]; Cable pulling [6150 h] | 246,000 | 6150,00 |  |  | XE50171810 | 6150 | 0 |  | 934 |  | 17 |  | 200 | 200 | C | LND | X | E | XE50 | 1718 | E | 17 | X | EL | LND | 1718 | 2011-05-20 | E-16-01-01 |  | 2012-02-10 |  | URMA | 2012-07-01 | 2011-10-01 | UDF_G3 | m | 12750 | 2012-01-25 | 2012-02-24 |  |  |  |
| XE601718 |  | CA17 ExtrBldgFl2 - Cable Termination & Testing | 60d | 2012-06-25 | 2012-08-24 | XE50171810 FF+20d, XE50171805 FF+20d, XB001718 | -44.5d | 16.12d |  | TB26 - 3 - Construction Normal 7days * CA17 | Cable connecting [200 pcs]; Cable connecting [500 h] | 20,000 | 500,00 |  |  | XE601718 | 500 | 0 |  | 934 |  | 17 |  | 200 | 200 | C | LND | X | E | XE60 | 1718 | E | 17 | X | ET | LND | 1718 | 2011-04-20 | E-16-02-01 |  | 2011-11-30 |  | URMA | 2012-08-14 | 2011-12-10 | UDF_G3 |  |  |  |  |  |  |  |
| XE50171805 |  | CA17 ExtrBldgFl2 - Cable Pulling Electric Part I (over SR1707) | 30d | 2012-06-27 | 2012-08-01 | XE501707 SS+12d, XE500C01, EE561718 (other project), XE401718 FF+10d | -38.5d | 0d |  | TB26 - V - Construct-Winter partly * | Cable pulling [6150 h]; Cable Pulling [12300 m] | 246,000 | 6150,00 |  |  | XE50171805 | 6150 | 0 |  | 934 |  | 17 |  | 200 | 200 | C | LND | X | E | XE50 | 1718 | E | 17 | X | EL | LND | 1718 | 2011-05-20 | E-16-01-01 |  | 2012-02-10 |  | URMA | 2012-07-01 | 2011-10-01 | UDF_G3 | m | 12750 | 2011-11-27 | 2011-12-26 |  |  |  |
|  | J | **Instrumentation** |  | 2012-01-21 | 2012-10-19 |  |  |  |  |  |  |  |  |  |  |  |  |  |  |  |  |  |  |  |  |  |  |  |  |  |  |  |  |  |  |  |  |  |  |  |  |  |  |  |  |  |  |  |  |  |  |  |  |
| XJ321718 |  | CA17 ExtrBldgFl2 - Install Junction Boxes | 40d | 2012-01-21 | 2012-03-01 | XR401718 FS-45d, EJ321718 (other project), XC911718, XX-21402 FF+10d | 7d | 33d |  | TB26 - 3 - Construction Normal 7days * CA17 | Junction Boxes/Cabinets/Panels [49 pcs]; Install Junction Boxes/ Cabinets/ Panels [1225 h] | 49,000 | 1225,00 |  |  | XJ321718 | 1225 | 0 | to be installed later | 934 |  | 17 |  | 200 | 200 | C | LND | X | J | XJ32 | 1718 | J | 17 | X | IN | LND | 1718 | 2011-07-10 | E-17-04-08 |  | 2012-03-20 |  | URMA | 2012-07-30 | 2011-11-10 | UDF_G2 |  |  |  |  |  |  |  |
| XJ421718 |  | CA17 ExtrBldgFl2 - Install Secondary Cable Trays | 60d | 2012-03-16 | 2012-05-16 | XR401718 FS-45d, XE401718 FS-20d, XJ321718 FS-20d, EJ46171810 (other project), XX-21402 FF+10d | -26d | 0d |  | TB26 - 3 - Construction Normal 7days * CA17 | Secondary cable trays [870 m]; Install secondary cable trays [3262.5 h] | 130,500 | 3262,50 |  |  | XJ421718 | 3262,5 | 0 | to be installed later | 934 |  | 17 |  | 200 | 200 | C | LND | X | J | XJ42 | 1718 | J | 17 | X | IN | LND | 1718 | 2011-06-10 | E-15-01-11 |  | 2011-11-30 |  | URMA | 2012-04-01 | 2011-09-20 | UDF_G1 | m | 1346 | 2011-09-07 | 2011-11-26 | x |  |  |
| XJ301718 |  | CA17 ExtrBldgFl2 - Install Field Instruments | 70d | 2012-03-18 | 2012-05-28 | XR401718 FS-45d, EJ361718 (other project), EJ360010 (other project), XR801718 FS-25d | 12d | 0d |  | TB26 - 3 - Construction Normal 7days * CA17 | Field Instruments [80 pcs]; Install field instruments [440 h] | 17,600 | 440,00 |  |  | XJ301718 | 440 | 0 | to be installed later | 934 |  | 17 |  | 200 | 200 | C | LND | X | J | XJ30 | 1718 | J | 17 | X | IN | LND | 1718 | 2011-07-10 | E-17-04-08 |  | 2012-03-20 |  | URMA | 2012-07-30 | 2011-11-10 |  |  |  |  |  |  |  |  |
| XJ441718 |  | CA17 ExtrBldgFl2 - Install Conduits to Instrm | 50d | 2012-04-25 | 2012-06-16 | XJ321718 FS-10d, XE401718, XJ421718 FS-20d, XR401718 FS-45d | -26d | 0d |  | TB26 - 3 - Construction Normal 7days * CA17 |  |  |  |  |  | XJ441718 | 0 | 0 |  | 934 |  | 17 |  | 200 | 200 | C | LND | X | J | XJ44 | 1718 | J | 17 | X | IN | LND | 1718 | 2011-07-10 | E-17-04-08 |  | 2012-03-20 |  | URMA | 2012-07-30 | 2011-11-10 | UDF_G1 |  |  |  |  |  |  |  |
| XJ701718 |  | CA17 ExtrBldgFl2 - Instrument Tubing | 40d | 2012-04-27 | 2012-06-07 | XJ301718 FS-30d | 12d | 38d |  | TB26 - 3 - Construction Normal 7days * CA17 |  |  |  |  |  | XJ701718 | 0 | 0 |  | 934 |  | 17 |  | 200 | 200 | C | LND | X | J | XJ70 | 1718 | J | 17 | X | IN | LND | 1718 | 2011-07-10 | E-17-04-08 |  | 2012-03-20 |  | URMA | 2012-07-30 | 2011-11-10 | UDF_G1 |  |  |  |  |  |  |  |
| XJ541718 |  | CA17 ExtrBldgFl2 - Pulling Singlecore Cables | 55d | 2012-05-28 | 2012-07-31 | XE500C01, EJ801718 (other project), XJ421718, XJ441718 FS-20d | -7d | 15d |  | TB26 - V - Construct-Winter partly * | Singlecore cables [7500 m]; Pull singlecore cables [5625 h] | 225,000 | 5625,00 |  |  | XJ541718 | 5625 | 0 |  | 934 |  | 17 |  | 200 | 200 | C | LND | X | J | XJ54 | 1718 | J | 17 | X | IN | LND | 1718 | 2011-07-10 | E-17-04-08 |  | 2012-03-20 |  | URMA | 2012-07-30 | 2011-11-10 | UDF_G1 | m | 7200 | 2012-02-10 | 2012-04-11 |  |  |  |
| XJ391718 |  | CA17 ExtrBldgFl2 - Install Earthing Field Eqpt | 40d | 2012-06-17 | 2012-07-26 | XJ301718 FF, XJ421718 FS-30d, XJ441718 | -26d | 0d |  | TB26 - 3 - Construction Normal 7days * CA17 |  |  |  |  |  | XJ391718 | 0 | 0 |  | 934 |  | 17 |  | 200 | 200 | C | LND | X | J | XJ39 | 1718 | J | 17 | X | IN | LND | 1718 | 2011-07-10 | E-17-04-08 |  | 2012-03-20 |  | URMA | 2012-07-30 | 2011-11-10 | UDF_G1 |  |  |  |  |  |  |  |
| XJ521718 |  | CA17 ExtrBldgFl2 - Pulling Multicore Cables | 60d | 2012-07-16 | 2012-09-24 | XJ321718 FS-20d, XE500C01, P3E00S (other project), XJ521707 FS-10d, XE401718 FS-20d, XJ521708 FS-10d | -51.5d | 0d |  | TB26 - V - Construct-Winter partly * | Multicore cables [9100 m]; Pull multicore cables [4550 h] | 182,000 | 4550,00 |  |  | XJ521718 | 4550 | 0 |  | 934 |  | 17 |  | 200 | 200 | C | LND | X | J | XJ52 | 1718 | J | 17 | X | IN | LND | 1718 | 2011-05-20 | E-17-01-01 |  | 2012-03-10 |  | URMA | 2012-06-16 | 2011-11-01 | UDF_G1 | m | 6565 | 2012-01-16 | 2012-03-27 |  |  |  |
| XJ641718 |  | CA17 ExtrBldgFl2 - Termin Singlecore Cables | 50d | 2012-07-17 | 2012-09-04 | XJ301718 FF+15d, XJ391718 FS-10d, XJ541718 FF+15d, XJ321718, XJ701718 | -26d | 34.62d |  | TB26 - 3 - Construction Normal 7days * CA17 | Termination Field [1412 mhr]; Termination field [1412 h] | 141,200 | 1412,00 |  |  | XJ641718 | 1412 | 0 |  | 934 |  | 17 |  | 200 | 200 | C | LND | X | J | XJ64 | 1718 | J | 17 | X | IN | LND | 1718 | 2011-07-10 | E-17-04-08 |  | 2012-03-20 |  | URMA | 2012-07-30 | 2011-11-10 | UDF_G1 |  |  |  |  |  |  |  |
| XJ621718 |  | CA17 ExtrBldgFl2 - Termin Multicore Cables | 50d | 2012-08-20 | 2012-10-09 | XH00171805, XJ521718 FS-30d, XJ321718 | -60.62d | 0d |  | TB26 - 3 - Construction Normal 7days * CA17 | Termination Field [2118 mhr]; Termination field [2118 h] | 211,800 | 2118,00 |  |  | XJ621718 | 2118 | 0 |  | 934 |  | 17 |  | 200 | 200 | C | LND | X | J | XJ62 | 1718 | J | 17 | X | IN | LND | 1718 | 2011-05-20 | E-17-01-01 |  | 2012-03-10 |  | URMA | 2012-06-16 | 2011-11-01 | UDF_G1 |  |  |  |  |  |  |  |
| XJ801718 |  | CA17 ExtrBldgFl2 - Inspections/ Mech. Acceptance/ Loop Checks | 40d | 2012-09-09 | 2012-10-19 | X3J120 FF, XJ391718 FS-30d, EJ801718 (other project), XJ641718 FS-30d, XJ621718 FS-30d, XJ701718, XE601718 | -60.62d | 55.88d |  | TB26 - 3 - Construction Normal 7days * CA17 | Loop Checks [430 pcs]; Loop checks [2150 h] | 86,000 | 2150,00 |  |  | XJ801718 | 2150 | 0 |  | 934 |  | 17 |  | 200 | 200 | C | LND | X | J | XJ80 | 1718 | J | 17 | X | LT | LND | 1718 | 2011-06-10 | E-17-02-01 |  | 2012-04-30 |  | URMA | 2012-08-18 | 2012-03-01 | UDF_G1 |  |  |  |  |  |  | 2012-08-18 |

Notes:
- XE911719: UDF_PREDECESSOR: XN30, DEL XE40, DEL XE80, DEL XJ40, Civil 100%, Equipment 100%
- XE401718: UDF_PREDECESSOR: XN30, Piping 50%
- XE801718: UDF_PREDECESSOR: XR40, Piping 50% pressure tests
- XE701718: UDF_PREDECESSOR: XE40, Civil 100%, HVAC ducts, Finishing works partly
- XE341718: UDF_PREDECESSOR: XE40, Equipment 100%, Piping 50%
- XE50171810: UDF_PREDECESSOR: XE40, XE50, DEL XE34
- XE601718: UDF_PREDECESSOR: XE50, Equipment 100%
- XE50171805: UDF_PREDECESSOR: XE40, XE50, DEL XE34
- XJ321718: UDF_PREDECESSOR: Civil 100%, Equipment 100%, Piping 50%
- XJ421718: UDF_PREDECESSOR: XE40, XJ32, Equipment 100%, Piping 50%
- XJ301718: UDF_PREDECESSOR: XR80, XR40, Equipment 100%, Piping 50%
- XJ441718: UDF_PREDECESSOR: XE40, XJ32, XJ40, Equipment 100%, Piping 50%
- XJ701718: UDF_PREDECESSOR: XJ30
- XJ541718: UDF_PREDECESSOR: XJ30, XJ42, XJ44
- XJ391718: UDF_PREDECESSOR: XJ30, XJ42, XJ44, DEL XJ32, DEL XR40
- XJ521718: UDF_PREDECESSOR: XE40, XJ32, XJ52
- XJ641718: UDF_PREDECESSOR: XJ30, XJ32, XJ39, XJ54, XJ70
- XJ621718: UDF_PREDECESSOR: XJ32, XJ52
- XJ801718: UDF_PREDECESSOR: XE60, XJ39, XJ62, XJ64, XJ70

| ID | WBS | Activity | Type | Duration | Start | Finish | Predecessors | Complete | Planned start | Planned finish | Total float | Free float | Constraint | Calendar | Resources | Cost | TB26 Ressource Budget | UDF_SELECT | UDF_SAVE ACT ID | UDF_BUDGETED LABOR UNIT | UDF_ACTUAL LABOR UNIT | Department | Constr. Area | PMT-Area | PMT-Schedule Org | PMT-Phase | PMT-Respons. | WBS Phase | WBS Discipline | WBS Type of Work | WBS Objects | Russia WBS Discipline (Russia) | Russia Construction Area | Russia WBS Phase | IMS | UPT | Russia WBS Objects | UDF_CONTRACT FINISH DATE | UDF_CONTRACT ITEM | Comments | UDF_Text4 | UDF_CONTRACT INDICATOR | UDF_SELECT UPDATE PROGRESS | UDF_CHECK BASELINE | Subcontractor | Zeigen/n. Zeigen | UDF_Concrete | Type of Work | UDF_CONTRACT START DATE | TB26 Semantics | UDF_EXPECTED START | UDF_EXPECTED FINISH | Inquiry/Order No |
| --- | --- | --- | --- | --- | --- | --- | --- | --- | --- | --- | --- | --- | --- | --- | --- | --- | --- | --- | --- | --- | --- | --- | --- | --- | --- | --- | --- | --- | --- | --- | --- | --- | --- | --- | --- | --- | --- | --- | --- | --- | --- | --- | --- | --- | --- | --- | --- | --- | --- | --- | --- | --- | --- |
|  | W | **Painting** |  |  | 2011-09-26 | 2012-01-16 |  |  |  |  |  |  |  |  |  |  |  |  |  |  |  |  |  |  |  |  |  |  |  |  |  |  |  |  |  |  |  |  |  |  |  |  |  |  |  |  |  |  |  |  |  |  |  |
| XW501718 |  | CA17 ExtrBldgFl2 - Surf.Protection Piping |  | 90d | 2011-09-26 | 2012-01-16 | XR201718 SS+10d |  |  |  | 369.5d |  |  |  | Piping painting [1056 sqm]; Piping painting [2640 h] | 1,921.63 | 2640,00 | OMUS-1 | XW501718 | 2640 | 0 | 934 | 17 | 200 | 200 | C | LND | X | W | XW50 | 1718 | W | 17 | X | PA | LND | 1718 |  |  |  |  |  |  |  |  |  |  |  |  |  |  |  |  |
|  | V | **Insulation** |  |  | 2012-01-21 | 2012-05-13 |  |  |  |  |  |  |  |  |  |  |  |  |  |  |  |  |  |  |  |  |  |  |  |  |  |  |  |  |  |  |  |  |  |  |  |  |  |  |  |  |  |  |  |  |  |  |  |
| XV301718 |  | CA17 ExtrBldgFl2 - Insulation Equipment |  | 100d | 2012-01-21 | 2012-05-02 | XE801718 FF+20d |  |  |  | 66d | 4d |  | TB26 - 3 - Construction Normal 7days * CA17 | Equipment insulation [350 sqm]; Equipment insulation [4375 h] | 1,370.27 | 4375,00 | OMUS-1 | XV301718 | 4375 | 0 | 934 | 17 | 200 | 200 | C | LND | X | V | XV30 | 1718 | V | 17 | X | INS | LND | 1718 | 2012-03-30 | E-13-03 |  |  |  |  |  |  |  |  |  |  |  |  |  |  |
| XV501718 |  | CA17 ExtrBldgFl2 - Insulation Piping |  | 90d | 2012-02-10 | 2012-05-13 | XE801718 FF+10d, XV301718 FF+6d, XR601718 SS+20d |  |  |  | 62d | 178.5d |  | TB26 - 3 - Construction Normal 7days * CA17 | Piping insulation [950 sqm]; Piping insulation [7125 h] | 5,475.16 | 7125,00 | OMUS-1 | XV501718 | 7125 | 0 | 934 | 17 | 200 | 200 | C | LND | X | V | XV50 | 1718 | V | 17 | X | INS | LND | 1718 | 2012-04-30 | E-13-01 |  |  |  |  |  |  |  |  |  |  |  |  |  |  |
|  | 20 | **CA17 - Extrusion Bldg 3rd Floor +19,05m** |  |  | 2011-02-17 | 2012-11-13 |  |  |  |  |  |  |  |  |  |  |  |  |  |  |  |  |  |  |  |  |  |  |  |  |  |  |  |  |  |  |  |  |  |  |  |  |  |  |  |  |  |  |  |  |  |  |  |
|  | C | **Civil Work** |  |  | 2011-07-20 | 2012-03-13 |  |  |  |  |  |  |  |  |  |  |  |  |  |  |  |  |  |  |  |  |  |  |  |  |  |  |  |  |  |  |  |  |  |  |  |  |  |  |  |  |  |  |  |  |  |  |  |
| XC40172030 |  | CA17 ExtrBldgFl3 - Concrete Works Stairtower North <24m (D-E/1-2) |  | 32d | 2011-07-20 A | 2011-08-20 A |  | 100% |  |  |  |  | start on or after 2011-07-20 | TB26 - 3 - Construction Normal 7days * CA17 | Concrete works [105 cbm]; Concrete works [3150 h] | 22,793.47 | 12300,00 |  | XC40172010 | 3150 | 0 | 934 | 17 | 200 | 200 | C | MO04 | X | C | XC40 | 1720 | C | 17 | X | EB | LND | 1720 |  |  | CA17 Critical | CA17 - critical - CW5 | UDF_G4 | 27.8. | x | MO11 |  |  |  |  |  |  |  |  |
| XC40172040 |  | CA17 ExtrBldgFl3 - Concrete Works Stairtower South <24m (D-E/4-5) |  | 29d | 2011-07-23 A | 2011-08-20 A |  | 100% |  |  |  |  | start on or after 2011-07-23 | TB26 - 3 - Construction Normal 7days * CA17 | Concrete works [138 cbm]; Concrete works [4140 h] | 22,793.47 | 12300,00 |  | XC40172010 | 4140 | 0 | 934 | 17 | 200 | 200 | C | MO04 | X | C | XC40 | 1720 | C | 17 | X | EB | LND | 1720 |  |  | CA17 Critical | CA17 - critical - CW5 | UDF_G4 | 27.8. | x | MO11 |  |  |  |  |  |  |  |  |
| XC40172005 |  | CA17 ExtrBldgFl3 - Precast Concrete Elements Stairtowers <24m North/South |  | 30d | 2011-08-08 A | 2011-08-17 A | EC48172010 (other project), IMS-C-000020 FF | 100% | 2011-09-20 | 2011-10-19 |  |  | as late as possible | TB26 - 3 - Construction Normal 7days * CA17 |  |  |  | MTA | XC40172005 | 0 | 0 | 934 | 17 | 200 | 200 | C | MO04 | X | C | XC40 | 1720 | C | 17 | X | pre | LND | 1720 |  |  |  | CA17 - critical - CW5 | UDF_G4 |  | x | MO11 |  |  |  |  |  |  |  |  |
| XC40172010 |  | CA17 ExtrBldgFl3 - Concrete Works Col/Wal <24m (A-F/1-5) |  | 30d | 2011-09-20 | 2011-10-19 | XC40171820 FS+25d, XC40171810 FS-10d |  |  |  | -4d | 0d |  | TB26 - 3 - Construction Normal 7days * CA17 | Concrete works [167 cbm]; Concrete works [5010 h] | 22,793.47 | 12300,00 |  | XC40172010 | 5010 | 0 | 934 | 17 | 200 | 200 | C | MO04 | X | C | XC40 | 1720 | C | 17 | X | EB | LND | 1720 |  |  |  | CA17 - critical - CW5 | UDF_G4 |  | x | MO11 |  |  |  |  |  |  |  |  |
| XC40172020 |  | CA17 ExtrBldgFl3 - Concrete Works Ceiling +24m |  | 25d | 2011-09-27 | 2011-10-21 | XN201720, EC48172020 (other project) FS+20d |  |  |  | -127d | 0d |  | TB26 - 3 - Construction Normal 7days * CA17 | Concrete works [630 cbm]; Concrete works [18900 h] | 5,321.43 | 18900,00 |  | XC40172020 | 18900 | 0 | 934 | 17 | 200 | 200 | C | MO04 | X | C | XC40 | 1720 | C | 17 | X | EB | LND | 1720 |  |  |  | CA17 - critical - CW5 | UDF_G4 |  |  | MO11 | C9-1 |  |  |  |  |  |  |  |
| XC40172015 |  | CA17 ExtrBldgFl3 - Erection Precast Elements Stairtowers <24m North/South |  | 10d | 2011-10-20 | 2011-10-29 | XC40172010, XC40172005, XC40171815 |  |  |  | -4d | 12d |  | TB26 - 3 - Construction Normal 7days * CA17 | Precast Concrete Works [60 cbm]; Precast concrete works [150 h] | 1,182.54 | 150,00 |  | XC40172015 | 150 | 0 | 934 | 17 | 200 | 200 | C | MO04 | X | C | XC40 | 1720 | C | 17 | X | EB | LND | 1720 |  |  |  | CA17 - critical - CW5 |  |  | x | MO11 |  |  |  |  |  |  |  |  |
| XC501720 |  | CA17 ExtrBldgFl3 - Finishing Works Rooms |  | 120d | 2011-11-05 | 2012-03-13 | XC510C00 FS+15d, IMS-C-000080 FF, XC40172020, XC001720 FF, P3S06S (other project) FF+20d, P3S09S (other project) FF+10d, EC501710 (other project) FS+20d |  |  |  | 67d | 0d |  | TB26 - 3 - Construction Normal 7days * CA17 | Finishing Works - Extrusion Building CA17 [33592 mhr]; Finishing Works - Extrusion building CA17 [33592 h] | 3,359,200 | 33592,00 | XC50 | XC501720 | 33592 | 0 | 934 | 17 | 200 | 200 | C | CiC | X | C | XC50 | 1720 | C | 17 | X | EB | LND | 1710 |  |  |  |  |  |  |  |  |  | 1 |  |  |  |  |  |  |
| XC501720_1 |  | CA17 ExtrBldgFl3 - Plastering and Painting |  | 20d | 2011-11-05 | 2011-11-24 | XC501720 SS |  |  |  | 67d | 0d |  | TB26 - 3 - Construction Normal 7days * CA17 |  |  | 33592,00 |  | XC501720 | 33592 | 0 | 934 | 17 | 200 | 200 | C | CiC | X | C | XC50 | 1720 | C | 17 | X | EB | LND | 1710 |  |  |  |  |  |  |  |  |  | 1 |  |  |  |  |  |  |
|  | N | **Structural Steel** |  |  | 2011-02-17 | 2012-01-16 |  |  |  |  |  |  |  |  |  |  |  |  |  |  |  |  |  |  |  |  |  |  |  |  |  |  |  |  |  |  |  |  |  |  |  |  |  |  |  |  |  |  |  |  |  |  |  |
| XN761701 |  | CA17 ExtrBldgFl3 SK1701- KMD Assy Drawings level 117m first lots | milestone | 0d | 2011-02-17 A | 2011-02-17 A |  | 100% |  |  |  |  | finish on 2011-02-17 | TB26 - 3 - Construction Normal 7days * CA17 |  |  | 22t |  | XN761701 | 0 | 0 | 934 | 17 | 200 | 200 | C | LND | X | N | XN05 | 1720 | N | 17 | X | SS | LND | 1720 |  |  |  |  |  |  | x |  | KMD |  | XNK |  |  |  |  |  |
| XN771701 |  | CA17 ExtrBldgFl3 SK1701- Steel Deliveries level 117m first lots | milestone | 0d | 2011-02-25 A | 2011-02-25 A |  | 100% |  |  |  |  | finish on 2011-02-25 | TB26 - 3 - Construction Normal 7days * CA17 |  |  | 22t |  | XN771701 | 0 | 0 | 934 | 17 | 200 | 200 | C | LND | X | N | XN06 | 1720 | N | 17 | X | SS | LND | 1720 |  |  |  |  |  |  |  |  | SD |  | XNK |  |  |  |  |  |
| XN781701 |  | CA17 ExtrBldgFl3 SK1701 - KMD Assy Drawings level 117m | milestone | 0d | 2011-03-27 A | 2011-03-27 A |  | 100% |  |  |  |  | finish on or after 2011-03-17 | TB26 - 3 - Construction Normal 7days * CA17 |  |  | 22t |  | XN781701 | 0 | 0 | 934 | 17 | 200 | 200 | C | LND | X | N | XN05 | 1720 | N | 17 | X | SS | LND | 1720 |  |  |  |  |  |  | x |  | KMD |  | XNK |  |  |  |  |  |
| XN791701 |  | CA17 ExtrBldgFl3 SK1701- Steel Deliveries level 117m | milestone | 0d | 2011-03-27 A | 2011-03-27 A |  | 100% |  |  |  |  | finish on 2011-03-25 | TB26 - 3 - Construction Normal 7days * CA17 |  |  | 22t |  | XN791701 | 0 | 0 | 934 | 17 | 200 | 200 | C | LND | X | N | XN06 | 1720 | N | 17 | X | SS | LND | 1720 |  |  |  |  |  |  |  |  | SD |  | XNK |  |  |  |  |  |
| XN201720 |  | CA17 ExtrBldgFl3 SK1701- Erec Prim Steel+M.Sheets <24m |  | 15d | 2011-09-12 | 2011-09-26 | XN781701, XN761701, XN771701 FS+10d, XN791701 FS+10d, P3N023N (other project), XN201718 FS-15d, XC40172030 FS-15d |  |  |  | -127d | 0d | start on or after 2011-09-12 | TB26 - 3 - Construction Normal 7days * CA17 | Piperacks, Main Structures [539 t]; Piperacks, Main structures [22907.5 h] | 4,966.67 | 22907,50 |  | XN201720 | 22907,5 | 0 | 934 | 17 | 200 | 200 | C | LND | X | N | XN20 | 1720 | N | 17 | X | SS | LND | 1720 | 2011-05-05 | E-04-14 | CA17 Critical | CA17 - critical - CW5 | UDF_G4 | 27.8. |  | ChSK | C9-1 |  | PU10 | 2011-03-25 | t | 2011-07-18 | 2011-08-26 | 2DC8990 |
| XN301720 |  | CA17 ExtrBldgFl3 SK1701 - Install Eqpt Platforms |  | 40d | 2011-09-27 | 2011-11-06 | P3N023N (other project), XN201720 |  |  |  | 34d | 0d |  | TB26 - 3 - Construction Normal 7days * CA17 | Ladders & platforms [23 t]; Ladders & platforms [2300 h] | 1,123.41 | 2300,00 |  | XN301720 | 2300 | 0 | 934 | 17 | 200 | 200 | C | LND | X | N | XN30 | 1720 | N | 17 | X | SS | LND | 1720 |  |  |  |  |  |  |  | ChSK |  |  | XNK |  | t |  |  |  |
| XN401720 |  | CA17 ExtrBldgFl3 SK1701 - Install Railings,Ladders,etc. |  | 40d | 2011-10-05 | 2011-11-14 | XN301720 FF+8d, EC701710 (other project), XN201720 SS+20d |  |  |  | 34d | 0d |  | TB26 - 3 - Construction Normal 7days * CA17 | Ladders & platforms | 155.21 | 0,00 |  | XN401720 | 0 | 0 | 934 | 17 | 200 | 200 | C | LND | X | N | XN40 | 1720 | N | 17 | X | SS | LND | 1720 |  |  |  |  |  |  |  | ChSK |  |  | XNK |  |  |  |  |  |
| XN601720 |  | CA17 ExtrBldgFl3 SK1701 - Install Gratings |  | 40d | 2011-10-10 | 2011-11-19 | PN691720 (other project), XN401720 FF+5d |  |  |  | 34d | 42d |  | TB26 - 3 - Construction Normal 7days * CA17 | Grating [300 sqm]; Grating [1125 h] | 8,639.94 | 1125,00 |  | XN601720 | 1125 | 0 | 934 | 17 | 200 | 200 | C | LND | X | N | XN60 | 1720 | N | 17 | X | SS | LND | 1720 |  |  |  |  |  |  |  | ChSK |  |  | XNK |  |  |  |  |  |
| XC701720 |  | CA17 ExtrBldgFl3 SK1701 - Install Supports Ceiling <24m |  | 50d | 2011-10-22 | 2011-12-11 | XC40172020, P3N023N (other project) |  |  |  | -8d | 0d |  | TB26 - 3 - Construction Normal 7days * CA17 | Piperacks, Main Structures [36 t]; Piperacks, Main structures [1530 h] |  | 1530,00 |  | XC701720 | 1530 | 0 | 934 | 17 | 200 | 200 | C | LND | X | C | XN70 | 1720 | N | 17 | X | SS | LND | 1720 |  |  |  |  |  |  |  | MO11 |  |  | XNK |  |  |  |  |  |
| XN801720 |  | CA17 ExtrBldgFl3 SK1701 - Install Cladding |  | 70d | 2011-10-31 | 2012-01-16 | EN801711 (other project), XN201720 SS+20d, P3N02§N (other project), P3N03N (other project) |  |  |  | -7d | 1d | start on or after 2011-10-31 | TB26 - 3 - Construction Normal 7days * CA17 | Cladding [1380 sqm]; Cladding [6900 h] | 2,266.04 | 6900,00 |  | XN801720 | 6900 | 0 | 934 | 17 | 200 | 200 | C | LND | X | N | XN80 | 1720 | N | 17 | X | SS | LND | 1720 |  |  |  |  |  |  |  | ChSK |  |  | XNK |  |  |  |  |  |

Notes:
- XW501718: P3 Activity Log Info: Clarification Surface Protection during Prefab
- XN771701: Scope: 09.02.2011: weight: 80 ton - Feb 80 ton
- XN791701: Scope: 09.02.2011: weight: 480 ton - Mrz 480 ton
- XN201720: Scope: 15.02.2011 (O.Siegel): die Liefermenge fьr Level 117m / belдuft sich auf 560 t. Da die Eqpt-Platforms 40 t wiegen, Support / Ceiling 30t wiegt, bleiben fьr Prim Steel 490 t.
- XN301720: Scope: 15.02.2011 (O.Siegel): die Liefermenge fьr Level 117m / belдuft sich auf 560 t. Da die Eqpt-Platforms 40 t wiegen, Support / Ceiling 30t wiegt, bleiben fьr Prim Steel 490 t.
- XC701720: Scope: 15.02.2011 (O.Siegel): die Liefermenge fьr Level 117m / belдuft sich auf 560 t. Da die Eqpt-Platforms 40 t wiegen, Support / Ceiling 30t wiegt, bleiben fьr Prim Steel 490 t.
- XN801720: Current Status: 2110806 Delivery end of September 2011 (Info from Fr. Schilka 02.08.2011)

| ID | WBS | Activity | Type | Duration | Start | Finish | Predecessors | Total float | Free float | Calendar | Resources | Cost | TB26 Ressource Budget | UDF_Weight (ton) | POSITION | WEIGHT | UDF_LEVEL | UDF_TAG No | UDF_Object No | UDF_PACKAGE | UDF_COMMENTS | UDF_SAVE ACT ID | UDF_BUDGETED LABOR UNIT | UDF_ACTUAL LABOR UNIT | Constr. Area | Zeigen/n. Zeigen | WBS Phase | WBS Discipline | WBS Objects | UDF_SELECT | UDF_CONTRACT START DATE | UDF_CONTRACT FINISH DATE | UDF_CONTRACT ITEM | Department | Type of Work | Inquiry/Order No | PMT-Area | PMT-Schedule Org | PMT-Phase | PMT-Respons. | WBS Type of Work | Russia WBS Discipline (Russia) | Russia Construction Area | Russia WBS Phase | IMS | UPT | Russia WBS Objects | UDF_CHECK BASELINE |
| --- | --- | --- | --- | --- | --- | --- | --- | --- | --- | --- | --- | --- | --- | --- | --- | --- | --- | --- | --- | --- | --- | --- | --- | --- | --- | --- | --- | --- | --- | --- | --- | --- | --- | --- | --- | --- | --- | --- | --- | --- | --- | --- | --- | --- | --- | --- | --- | --- |
|  | H | **HVAC** |  |  |  |  |  |  |  |  |  |  |  |  |  |  |  |  |  |  |  |  |  |  |  |  |  |  |  |  |  |  |  |  |  |  |  |  |  |  |  |  |  |  |  |  |  |  |
|  | U | **Package Units** |  |  |  |  |  |  |  |  |  |  |  |  |  |  |  |  |  |  |  |  |  |  |  |  |  |  |  |  |  |  |  |  |  |  |  |  |  |  |  |  |  |  |  |  |  |  |
|  | B | **Mechanical - Stationary Equipment** |  |  | 2011-11-07 | 2012-01-18 |  |  |  |  |  |  |  |  |  |  |  |  |  |  |  |  |  |  |  |  |  |  |  |  |  |  |  |  |  |  |  |  |  |  |  |  |  |  |  |  |  |  |
| HP-21401 |  | ADDITIVE HOPPER |  | 10d | 2011-11-07 | 2011-11-17 | XC40172020, XB001720 SS, ER291700 (other project), P3U02S5 (other project), XB001720 FF, XN301720 | 52d | 0d |  | Static Equipment < 10 tons [0.85 t]; Static equipment < 10t [85 h] | 3,400 | 85,00 | 0,85 | a | 850 | structure +25.35 | HP-21401 | SK1720 | PU02 ADDITIVE SYSTEM COMPONENTS (PK-21-/22401) | installation BEVORE Ceiling 4th floor | HP-21401 | 85 | 0 | 17 | EQ | X | B | 1720 |  |  |  |  |  |  |  |  |  |  |  |  |  |  |  |  |  |  |  |
| HP-21402 |  | ADDITIVE HOPPER |  | 15d | 2011-11-07 | 2011-11-23 | XB001720 SS, ER291700 (other project), XC40172020, P3U02S5 (other project), XB001720 FF, XN301720 | 53d | 27d |  | Static Equipment < 10 tons [0.85 t]; Static equipment < 10t [85 h] | 3,400 | 85,00 | 0,85 | a | 850 | structure +25.35 | HP-21402 | SK1720 | PU02 ADDITIVE SYSTEM COMPONENTS (PK-21-/22401) | installation BEVORE Ceiling 4th floor | HP-21402 | 85 | 0 | 17 | EQ | X | B | 1720 |  |  |  |  |  |  |  |  |  |  |  |  |  |  |  |  |  |  |  |
| HP-21403 |  | ADDITIVE HOPPER |  | 15d | 2011-11-07 | 2011-11-23 | P3U02S5 (other project), XB001720 SS, ER291700 (other project), XB001720 FF, XC40172020, XN301720 | 53d | 27d |  | Static Equipment < 10 tons [0.85 t]; Static equipment < 10t [85 h] | 3,400 | 85,00 | 0,85 | a | 850 | structure +25.35 | HP-21403 | SK1720 | PU02 ADDITIVE SYSTEM COMPONENTS (PK-21-/22401) | installation BEVORE Ceiling 4th floor | HP-21403 | 85 | 0 | 17 | EQ | X | B | 1720 |  |  |  |  |  |  |  |  |  |  |  |  |  |  |  |  |  |  |  |
| HP-21404 |  | PEROXIDE HOPPER |  | 15d | 2011-11-07 | 2011-11-23 | XB001720 SS, XC40172020, XB001720 FF, ER291700 (other project), P3U02S5 (other project), XN301720 | 53d | 27d |  | Static Equipment < 10 tons [1.5 t]; Static equipment < 10t [150 h] | 6,000 | 150,00 | 1,5 | a | 1500 | structure +25.35 | HP-21404 | SK1720 | PU02 ADDITIVE SYSTEM COMPONENTS (PK-21-/22401) | installation BEVORE Ceiling 4th floor | HP-21404 | 150 | 0 | 17 | EQ | X | B | 1720 |  |  |  |  |  |  |  |  |  |  |  |  |  |  |  |  |  |  |  |
| HP-21405 |  | ADDITIVE HOPPER |  | 10d | 2011-11-07 | 2011-11-17 | P3U02S5 (other project), XC40172020, ER291700 (other project), XB001720 FF, XB001720 SS, XN301720 | 52d | 0d |  | Static Equipment < 10 tons [0.85 t]; Static equipment < 10t [85 h] | 3,400 | 85,00 | 0,85 | a | 850 | structure +25.35 | HP-21405 | SK1720 | PU02 ADDITIVE SYSTEM COMPONENTS (PK-21-/22401) | installation BEVORE Ceiling 4th floor | HP-21405 | 85 | 0 | 17 | EQ | X | B | 1720 |  |  |  |  |  |  |  |  |  |  |  |  |  |  |  |  |  |  |  |
| HP-21407 |  | ADDITIVE HOPPER |  | 15d | 2011-11-07 | 2011-11-23 | P3U02S5 (other project), XC40172020, ER291700 (other project), XB001720 FF, XB001720 SS, XN301720 | 53d | 27d |  | Static Equipment < 10 tons [1.5 t]; Static equipment < 10t [150 h] | 6,000 | 150,00 | 1,5 | a | 1500 | structure +25.35 | HP-21407 | SK1720 | PU02 ADDITIVE SYSTEM COMPONENTS (PK-21-/22401) | installation BEVORE Ceiling 4th floor | HP-21407 | 150 | 0 | 17 | EQ | X | B | 1720 |  |  |  |  |  |  |  |  |  |  |  |  |  |  |  |  |  |  |  |
| HP-21408 |  | TALC HOPPER |  | 15d | 2011-11-07 | 2011-11-23 | P3U02S5 (other project), XC40172020, XB001720 SS, XB001720 FF, ER291700 (other project), XN301720 | 53d | 27d |  | Static Equipment < 10 tons [1.5 t]; Static equipment < 10t [150 h] | 6,000 | 150,00 | 1,5 | a | 1500 | structure +25.35 | HP-21408 | SK1720 | PU02 ADDITIVE SYSTEM COMPONENTS (PK-21-/22401) | installation BEVORE Ceiling 4th floor | HP-21408 | 150 | 0 | 17 | EQ | X | B | 1720 |  |  |  |  |  |  |  |  |  |  |  |  |  |  |  |  |  |  |  |
| HP-22401 |  | ADDITIVE HOPPER |  | 10d | 2011-11-07 | 2011-11-17 | XC40172020, XB001720 SS, XB001720 FF, ER291700 (other project), P3U02S5 (other project), XN301720 | 52d | 0d |  | Static Equipment < 10 tons [0.85 t]; Static equipment < 10t [85 h] | 3,400 | 85,00 | 0,85 | a | 850 | structure +25.35 | HP-22401 | SK1720 | PU02 ADDITIVE SYSTEM COMPONENTS (PK-21-/22401) | installation BEVORE Ceiling 4th floor | HP-22401 | 85 | 0 | 17 | EQ | X | B | 1720 |  |  |  |  |  |  |  |  |  |  |  |  |  |  |  |  |  |  |  |
| HP-22402 |  | ADDITIVE HOPPER |  | 15d | 2011-11-07 | 2011-11-23 | ER291700 (other project), P3U02S5 (other project), XC40172020, XB001720 FF, XB001720 SS, XN301720 | 53d | 27d |  | Static Equipment < 10 tons [0.85 t]; Static equipment < 10t [85 h] | 3,400 | 85,00 | 0,85 | a | 850 | structure +25.35 | HP-22402 | SK1720 | PU02 ADDITIVE SYSTEM COMPONENTS (PK-21-/22401) | installation BEVORE Ceiling 4th floor | HP-22402 | 85 | 0 | 17 | EQ | X | B | 1720 |  |  |  |  |  |  |  |  |  |  |  |  |  |  |  |  |  |  |  |
| HP-22403 |  | ADDITIVE HOPPER |  | 15d | 2011-11-07 | 2011-11-23 | P3U02S5 (other project), ER291700 (other project), XC40172020, XB001720 FF, XB001720 SS, XN301720 | 53d | 27d |  | Static Equipment < 10 tons [0.85 t]; Static equipment < 10t [85 h] | 3,400 | 85,00 | 0,85 | a | 850 | structure +25.35 | HP-22403 | SK1720 | PU02 ADDITIVE SYSTEM COMPONENTS (PK-21-/22401) | installation BEVORE Ceiling 4th floor | HP-22403 | 85 | 0 | 17 | EQ | X | B | 1720 |  |  |  |  |  |  |  |  |  |  |  |  |  |  |  |  |  |  |  |
| HP-22404 |  | PEROXIDE HOPPER |  | 15d | 2011-11-07 | 2011-11-23 | ER291700 (other project), XB001720 SS, XB001720 FF, P3U02S5 (other project), XC40172020, XN301720 | 50d | 27d |  | Static Equipment < 10 tons [1.5 t]; Static equipment < 10t [150 h] | 6,000 | 150,00 | 1,5 | a | 1500 | structure +25.35 | HP-22404 | SK1720 | PU02 ADDITIVE SYSTEM COMPONENTS (PK-21-/22401) | installation BEVORE Ceiling 4th floor | HP-22404 | 150 | 0 | 17 | EQ | X | B | 1720 |  |  |  |  |  |  |  |  |  |  |  |  |  |  |  |  |  |  |  |
| HP-22405 |  | ADDITIVE HOPPER |  | 10d | 2011-11-07 | 2011-11-17 | P3U02S5 (other project), XB001720 SS, XC40172020, XB001720 FF, ER291700 (other project), XN301720 | 52d | 0d |  | Static Equipment < 10 tons [0.85 t]; Static equipment < 10t [85 h] | 3,400 | 85,00 | 0,85 | a | 850 | structure +25.35 | HP-22405 | SK1720 | PU02 ADDITIVE SYSTEM COMPONENTS (PK-21-/22401) | installation BEVORE Ceiling 4th floor | HP-22405 | 85 | 0 | 17 | EQ | X | B | 1720 |  |  |  |  |  |  |  |  |  |  |  |  |  |  |  |  |  |  |  |
| HP-22407 |  | ADDITIVE HOPPER |  | 15d | 2011-11-07 | 2011-11-23 | ER291700 (other project), P3U02S5 (other project), XB001720 SS, XC40172020, XB001720 FF, XN301720 | 53d | 27d |  | Static Equipment < 10 tons [1.5 t]; Static equipment < 10t [150 h] | 6,000 | 150,00 | 1,5 | a | 1500 | structure +25.35 | HP-22407 | SK1720 | PU02 ADDITIVE SYSTEM COMPONENTS (PK-21-/22401) | installation BEVORE Ceiling 4th floor | HP-22407 | 150 | 0 | 17 | EQ | X | B | 1720 |  |  |  |  |  |  |  |  |  |  |  |  |  |  |  |  |  |  |  |
| XB001720 |  | CA17 ExtrBldgFl3 - Install Static Eqpt | level of effort | 66d | 2011-11-07 | 2012-01-18 |  | 27d | 0d | TB26 - 3 - Construction Normal 7days * CA17 |  |  | 16 |  |  |  |  |  |  |  |  | XB001720 | 0 | 0 | 17 |  | X | B | 1720 | OMUS-1 | 2011-05-20 | 2011-08-05 | E-08-01-14 | 934 | PU10 | 2DC8990 | 200 | 200 | C | LND | XB00 | B | 17 | X | EQ | LND | 1720 |  |
| RF-21411 |  | ADDITIVE HOPPER |  | 5d | 2011-12-26 | 2011-12-30 | XB001720 FF, ER291700 (other project), XC40173020, P3U02S4 (other project), XB001720 SS, HP-21401 | 33d | 39.88d |  | Static Equipment < 10 tons [0.1 t]; Static equipment < 10t [10 h] | 400 | 10,00 | 0,105 | a | 1500 | at HP-21401 +20.50 | RF-21411 | SK1720 | PU02 ADDITIVE SYSTEM COMPONENTS (PK-21-/22401) |  | RF-21411 | 10 | 0 | 17 | EQ | X | B | 1720 |  |  |  |  |  |  |  |  |  |  |  |  |  |  |  |  |  |  |  |
| RF-21412 |  | ADDITIVE HOPPER |  | 5d | 2011-12-26 | 2011-12-30 | XB001720 FF, P3U02S4 (other project), HP-21402, XC40173020, ER291700 (other project), XB001720 SS | 33d | 39.88d |  | Static Equipment < 10 tons [0.1 t]; Static equipment < 10t [10 h] | 400 | 10,00 | 0,105 | a | 1500 | at HP-21402 +20.50 | RF-21412 | SK1720 | PU02 ADDITIVE SYSTEM COMPONENTS (PK-21-/22401) |  | RF-21412 | 10 | 0 | 17 | EQ | X | B | 1720 |  |  |  |  |  |  |  |  |  |  |  |  |  |  |  |  |  |  |  |
| RF-21413 |  | ADDITIVE HOPPER |  | 5d | 2011-12-26 | 2011-12-30 | XB001720 SS, XB001720 FF, HP-21403, ER291700 (other project), P3U02S4 (other project), XC40173020 | 33d | 39.88d |  | Static Equipment < 10 tons [0.1 t]; Static equipment < 10t [10 h] | 400 | 10,00 | 0,105 | a | 1500 | at HP-21403 +20.50 | RF-21413 | SK1720 | PU02 ADDITIVE SYSTEM COMPONENTS (PK-21-/22401) |  | RF-21413 | 10 | 0 | 17 | EQ | X | B | 1720 |  |  |  |  |  |  |  |  |  |  |  |  |  |  |  |  |  |  |  |
| RF-21414 |  | PEROXIDE HOPPER FEEDER |  | 5d | 2011-12-26 | 2011-12-30 | ER291700 (other project), XB001720 SS, HP-21404, P3U02S4 (other project), XB001720 FF, XC40173020 | 33d | 39.88d |  | Static Equipment < 10 tons [0.1 t]; Static equipment < 10t [10 h] | 400 | 10,00 | 0,135 | a | 1500 | at HP-21404 +20.50 | RF-21414 | SK1720 | PU02 ADDITIVE SYSTEM COMPONENTS (PK-21-/22401) |  | RF-21414 | 10 | 0 | 17 | EQ | X | B | 1720 |  |  |  |  |  |  |  |  |  |  |  |  |  |  |  |  |  |  |  |
| RF-21415 |  | ADDITIVE HOPPER |  | 5d | 2011-12-26 | 2011-12-30 | XB001720 SS, XC40173020, HP-21405, P3U02S4 (other project), ER291700 (other project), XB001720 FF | 33d | 39.88d |  | Static Equipment < 10 tons [0.1 t]; Static equipment < 10t [10 h] | 400 | 10,00 | 0,105 | a | 1500 | at HP-21405 +20.50 | RF-21415 | SK1720 | PU02 ADDITIVE SYSTEM COMPONENTS (PK-21-/22401) |  | RF-21415 | 10 | 0 | 17 | EQ | X | B | 1720 |  |  |  |  |  |  |  |  |  |  |  |  |  |  |  |  |  |  |  |
| RF-21417 |  | ADDITIVE HOPPER |  | 5d | 2011-12-26 | 2011-12-30 | XC40173020, XB001720 SS, XB001720 FF, HP-21407, ER291700 (other project), P3U02S4 (other project) | 33d | 39.88d |  | Static Equipment < 10 tons [0.1 t]; Static equipment < 10t [10 h] | 400 | 13,50 | 0,105 | a | 1500 | at HP-21407 +20.50 | RF-21417 | SK1720 | PU02 ADDITIVE SYSTEM COMPONENTS (PK-21-/22401) |  | RF-21417 | 10 | 0 | 17 | EQ | X | B | 1720 |  |  |  |  |  |  |  |  |  |  |  |  |  |  |  |  |  |  |  |
| RF-21418 |  | TALK HOPPER FEEDER |  | 5d | 2011-12-26 | 2011-12-30 | HP-21408, XB001720 SS, XB001720 FF, ER291700 (other project), P3U02S4 (other project), XC40173020 | 33d | 39.88d |  | Static Equipment < 10 tons [0.14 t]; Static equipment < 10t [13.5 h] | 540 | 13,50 | 0,135 | a | 1500 | at HP-21408 +20.50 | RF-21418 | SK1720 | PU02 ADDITIVE SYSTEM COMPONENTS (PK-21-/22401) |  | RF-21418 | 13,5 | 0 | 17 | EQ | X | B | 1720 |  |  |  |  |  |  |  |  |  |  |  |  |  |  |  |  |  |  | x |
| RF-22411 |  | ADDITIVE HOPPER |  | 5d | 2011-12-26 | 2011-12-30 | XB001720 FF, XC40173020, XC40172020, ER291700 (other project), HP-22401, P3U02S4 (other project), XB001720 SS | 33d | 39.88d |  | Static Equipment < 10 tons [0.1 t]; Static equipment < 10t [10 h] | 400 | 10,00 | 0,105 | a | 1500 | at HP-22401 +20.50 | RF-22411 | SK1720 | PU02 ADDITIVE SYSTEM COMPONENTS (PK-21-/22401) |  | RF-22411 | 10 | 0 | 17 | EQ | X | B | 1720 |  |  |  |  |  |  |  |  |  |  |  |  |  |  |  |  |  |  |  |
| RF-22412 |  | ADDITIVE HOPPER |  | 5d | 2011-12-26 | 2011-12-30 | XC40172020, ER291700 (other project), XB001720 SS, XC40173020, P3U02S4 (other project), XB001720 FF, HP-22402 | 33d | 0d |  | Static Equipment < 10 tons [0.1 t]; Static equipment < 10t [10 h] | 400 | 10,00 | 0,105 | a | 1500 | at HP-22402 +20.50 | RF-22412 | SK1720 | PU02 ADDITIVE SYSTEM COMPONENTS (PK-21-/22401) |  | RF-22412 | 10 | 0 | 17 | EQ | X | B | 1720 |  |  |  |  |  |  |  |  |  |  |  |  |  |  |  |  |  |  |  |
| RF-22413 |  | ADDITIVE HOPPER |  | 5d | 2011-12-26 | 2011-12-30 | HP-22403, XC40172020, XB001720 FF, P3U02S4 (other project), ER291700 (other project), XC40173020, XB001720 SS | 33d | 39.88d |  | Static Equipment < 10 tons [0.1 t]; Static equipment < 10t [10 h] | 400 | 10,00 | 0,105 | a | 1500 | at HP-22403 +20.50 | RF-22413 | SK1720 | PU02 ADDITIVE SYSTEM COMPONENTS (PK-21-/22401) |  | RF-22413 | 10 | 0 | 17 | EQ | X | B | 1720 |  |  |  |  |  |  |  |  |  |  |  |  |  |  |  |  |  |  |  |
| RF-22414 |  | PEROXIDE HOPPER FEEDER |  | 5d | 2011-12-26 | 2011-12-30 | ER291700 (other project), XB001720 FF, P3U02S4 (other project), XC40173020, HP-22404, XB001720 SS, XC40172020 | 23d | 0d |  | Static Equipment < 10 tons [0.14 t]; Static equipment < 10t [13.5 h] | 540 | 13,50 | 0,135 | a | 1500 | at HP-22403 +20.50 | RF-22414 | SK1720 | PU02 ADDITIVE SYSTEM COMPONENTS (PK-21-/22401) |  | RF-22414 | 13,5 | 0 | 17 | EQ | X | B | 1720 |  |  |  |  |  |  |  |  |  |  |  |  |  |  |  |  |  |  |  |
| RF-22415 |  | ADDITIVE HOPPER |  | 5d | 2011-12-26 | 2011-12-30 | ER291700 (other project), XC40172020, XC40173020, XB001720 FF, HP-22405, P3U02S4 (other project), XB001720 SS | 33d | 39.88d |  | Static Equipment < 10 tons [0.1 t]; Static equipment < 10t [10 h] | 400 | 10,00 | 0,105 | a | 1500 | at HP-22405 +20.50 | RF-22415 | SK1720 | PU02 ADDITIVE SYSTEM COMPONENTS (PK-21-/22401) |  | RF-22415 | 10 | 0 | 17 | EQ | X | B | 1720 |  |  |  |  |  |  |  |  |  |  |  |  |  |  |  |  |  |  |  |
| RF-22417 |  | ADDITIVE HOPPER |  | 5d | 2011-12-26 | 2011-12-30 | HP-22407, XC40172020, XB001720 SS, XB001720 FF, XC40173020, P3U02S4 (other project), ER291700 (other project) | 33d | 39.88d |  | Static equipment < 10t [10 h]; Static Equipment < 10 tons [0.1 t] | 400 | 10,00 | 0,105 | a | 1500 | at HP-22407 +20.50 | RF-22417 | SK1720 | PU02 ADDITIVE SYSTEM COMPONENTS (PK-21-/22401) |  | RF-22417 | 10 | 0 | 17 | EQ | X | B | 1720 |  |  |  |  |  |  |  |  |  |  |  |  |  |  |  |  |  |  |  |

| ID | WBS | Activity | Type | Duration | Start | Finish | Predecessors | Total float | Free float | Constraint | Calendar | Resources | Cost | UDF_SELECT | UDF_CONTRACT START DATE | UDF_CONTRACT FINISH DATE | UDF_CONTRACT ITEM | UDF_SAVE ACT ID | UDF_BUDGETED LABOR UNIT | UDF_ACTUAL LABOR UNIT | Department | Type of Work | Constr. Area | PMT-Area | PMT-Schedule Org | PMT-Phase | PMT-Respons. | WBS Phase | WBS Discipline | WBS Type of Work | WBS Objects | Russia WBS Discipline (Russia) | Russia Construction Area | Russia WBS Phase | IMS | UPT | Russia WBS Objects | TB26 Ressource Budget | UDF_COMMENTS_0827 | Inquiry/Order No | UDF_PLANNED START | UDF_PLANNED FINISH | Subcontractor | UDF_CONTRACT FINISH DATE REV1 | UDF_CONTRACT START DATE REV1 | UDF_INDICATOR | TB26 Semantics | TB26 Material Res Values | UDF_ELECTRICAL START | UDF_ELECTRICAL FINISH | UDF_CHECK BASELINE | UDF_Vendor Representatives | UDF_PENALIZED FINISH |
| --- | --- | --- | --- | --- | --- | --- | --- | --- | --- | --- | --- | --- | --- | --- | --- | --- | --- | --- | --- | --- | --- | --- | --- | --- | --- | --- | --- | --- | --- | --- | --- | --- | --- | --- | --- | --- | --- | --- | --- | --- | --- | --- | --- | --- | --- | --- | --- | --- | --- | --- | --- | --- | --- |
|  | M | **Mechanical - Rotating Equipment** |  |  | 2011-11-18 | 2011-12-12 |  |  |  |  |  |  |  |  |  |  |  |  |  |  |  |  |  |  |  |  |  |  |  |  |  |  |  |  |  |  |  |  |  |  |  |  |  |  |  |  |  |  |  |  |  |  |  |
| XM001720 |  | CA17 ExtrBldgFl3 - Install Rotating Eqpt | level of effort | 25d | 2011-11-18 | 2011-12-12 | RF-21304 FF, RF-21304 SS, RF-22304 SS, RF-22304 FF | 61d | 0d |  | TB26 - 3 - Construction Normal 7days * CA17 |  |  | OMUS-1 | 2011-05-20 | 2011-08-05 | E-08-01-14 | XM001720 | 0 | 0 | 934 | XBB | 17 | 200 | 200 | C | LND | X | M | XM00 | 1720 | M | 17 | X | EQ | LND | 1720 |  |  |  |  |  |  |  |  |  |  |  |  |  |  |  |  |
|  | R | **Piping** |  |  | 2011-09-15 | 2012-04-28 |  |  |  |  |  |  |  |  |  |  |  |  |  |  |  |  |  |  |  |  |  |  |  |  |  |  |  |  |  |  |  |  |  |  |  |  |  |  |  |  |  |  |  |  |  |  |  |
| XR201720 |  | CA17 ExtrBldgFl3 - Piping Prefabrication |  | 108d | 2011-09-15 | 2012-01-08 | ER49172005 (other project) SS+12d, P3U10S1B (other project), ER491720 (other project) SS+12d, XR500C00 FS+15d | 19d | 27d | start on or after 2011-09-15 | TB26 - 3 - Construction Normal 7days * CA17 | A/G piping prefabrication [1870 Fpi]; Conveying S. piping prefabrication [150 Fpi]; A/G Piping (Prefab) [7012.5 h]; Conveying system (Prefab) [375 h] | 25,602.22 | OMUS-1 |  |  |  | XR201720 | 7387,5 | 0 | 934 | PU10 | 17 | 200 | 200 | C | LND | X | R | XR20 | 1720 | R | 17 | X | PRP | LND | 1720 | 7387,50 | Start mid of sept | 2DC8990 |  |  |  |  |  |  |  |  |  |  |  |  |  |
| XR401720 |  | CA17 ExtrBldgFl3 - Piping Installation |  | 90d | 2011-12-12 | 2012-03-19 | HP-22404 FF+20d, RF-22414 FF+20d, RF-21413 FF+20d, P3J04IS (other project), HP-21402 FF+20d, RF-22415 FF+20d, XR201720 FF+10d, HP-21441 FF+20d, XC701720, XR201720 SS+60d, HP-22441 FF+20d, RF-22304 FF+20d, P3J02AS (other project), HP-21403 FF+20d, HP-22401 FF+20d, HP-22403 FF+20d, RF-21418 FF+20d, RF-22413 FF+20d, RF-21414 FF+20d, PK-21453 FF+20d, P3J01AS (other project), XN601720 SS+20d, HP-21407 FF+20d, RF-22417 FF+20d, RF-21304 FF+20d, P3J02S (other project) FF, P3J02DS (other project), HP-21404 FF+20d, RF-21417 FF+20d, RF-21415 FF+20d, RF-22411 FF+20d, IMS-C-000190 FF, XN801720 FS-30d, HP-21401 FF+20d, HP-21408 FF+20d, HP-22405 FF+20d, RF-21412 FF+20d, RF-21411 FF+20d, RF-22412 FF+20d, P3J04CS1 (other project), P3S06S (other project) FF+20d, HP-21405 FF+20d, HP-22402 FF+20d, HP-22407 FF+20d, P3R09AS (other project) FF+20d | -8d | 0d |  | TB26 - 3 - Construction Normal 7days * CA17 | A/G piping field installation [2300 Fpi]; Conveying S. piping field installation [110 Fpi]; Control & Shut-off valves [26 pcs]; A/G Piping (Field) [14375 h]; Conveying system (Field) [550 h]; Install Control & Shut-off Valves [136.5 h] | 59,653.49 | OMUS-1 | 2011-02-25 | 2012-02-25 | E-06-03-07 | XR401720 | 15061,5 | 0 | 934 | PU10 | 17 | 200 | 200 | C | LND | X | R | XR40 | 1720 | R | 17 | X | PI | LND | 1720 | 15061,50 |  | 2DC8990 | 2011-05-12 |  |  |  |  |  |  |  |  |  |  |  |  |
| XR601720 |  | CA17 ExtrBldgFl3 - Piping Pressure Tests |  | 60d | 2012-02-17 | 2012-04-18 | XR401720 FF+30d, XR401720 SS+45d | -8d | 0d |  | TB26 - 3 - Construction Normal 7days * CA17 |  |  | OMUS-1 | 2011-02-25 | 2012-02-25 | E-06-03-07 | XR601720 | 0 | 0 | 934 |  | 17 | 200 | 200 | C | LND | X | R | XR60 | 1720 | R | 17 | X | HY | LND | 1720 | 1241 |  |  |  |  |  |  |  |  |  |  |  |  |  |  |  |
| XR801720 |  | CA17 ExtrBldgFl3 - Piping Reinstatement |  | 50d | 2012-03-10 | 2012-04-28 | XR601720 FF+10d, IMS-C-000360 FF | -8d | 0d |  | TB26 - 3 - Construction Normal 7days * CA17 |  |  | OMUS-1 | 2011-02-25 | 2012-02-25 | E-06-03-07 | XR801720 | 0 | 0 | 934 |  | 17 | 200 | 200 | C | LND | X | R | XR80 | 1720 | R | 17 | X | PI | LND | 1720 | 620 |  |  |  | 2012-05-11 |  |  |  |  |  |  |  |  |  |  |  |
|  | E | **Electrical** |  |  | 2011-10-22 | 2012-10-03 |  |  |  |  |  |  |  |  |  |  |  |  |  |  |  |  |  |  |  |  |  |  |  |  |  |  |  |  |  |  |  |  |  |  |  |  |  |  |  |  |  |  |  |  |  |  |  |
| XC911720 |  | CA17 ExtrBldgFl3 - Install Earthing&Lightn.Sys_CIVIL |  | 40d | 2011-10-22 | 2011-12-01 | EE901720 (other project), XC40172020 | 60d | 55d |  | TB26 - 3 - Construction Normal 7days * CA17 | Grounding & Lightning [240 pcs]; Grounding & Lightning [2700 h] | 108,000 |  | 2011-08-10 | 2012-01-20 | E-16-07-09 | XC911720 | 2700 | 0 | 934 |  | 17 | 200 | 200 | C | LND | X | C | XE91 | 1720 | C | 17 | X | EA | LND | 1720 | 2700,00 |  |  |  |  | MO11 |  |  |  |  |  |  |  |  |  |  |
| XE911721 |  | CA17 ExtrBldgFl3 - Install Earthing&Lightn.Sys_E/I |  | 20d | 2011-12-31 | 2012-01-26 | XN301720, RF-22412 | 151d | 262.5d |  | TB26 - 3 - Construction Normal 7days * CA17 |  |  |  | 2011-08-10 | 2012-01-20 | E-16-07-09 | XE911721 | 0 | 0 | 934 |  | 17 | 200 | 200 | C | LND | X | E | XE91 | 1720 | E | 17 | X | EA | LND | 1720 | 265 |  |  |  |  | URMA | 2012-07-15 | 2011-11-10 | UDF_G2 |  |  |  |  |  |  |  |
| XE401720 |  | CA17 ExtrBldgFl3 - Install Cable Trays |  | 40d | 2012-02-07 | 2012-03-19 | EE46172010 (other project), XN801720, XR401720 FS-40d | 0d |  |  | TB26 - 3 - Construction Normal 7days * CA17 | Cable trays/conduits [880 m]; Cable trays [2640 h] | 105,600 |  | 2011-06-10 | 2011-11-30 | E-15-01-11 | XE401720 | 2640 | 0 | 934 |  | 17 | 200 | 200 | C | LND | X | E | XE40 | 1720 | E | 17 | X | EL | LND | 1720 | 2640,00 |  |  |  |  | URMA | 2012-04-01 | 2011-09-20 | UDF_G3 | m | 2200 | 2011-09-30 | 2011-12-19 | x |  |  |
| XE341720 |  | CA17 ExtrBldgFl3 - Install Local Operation Panels |  | 50d | 2012-02-17 | 2012-04-08 | EE46172010 (other project), XE401720 FF, XR401720 FS-30d, RF-22412 | 20d | 114.5d |  | TB26 - 3 - Construction Normal 7days * CA17 | Field Panels [11 pcs]; Field panels [220 h] | 8,800 |  | 2011-08-10 | 2012-01-20 | E-16-07-09 | XE341720 | 220 | 0 | 934 |  | 17 | 200 | 200 | C | LND | X | E | XE34 | 1720 | E | 17 | X | EL | LND | 1720 | 220,00 |  |  |  |  | URMA | 2012-07-15 | 2011-11-10 | UDF_G2 |  |  |  |  |  |  |  |
| XE701720 |  | CA17 ExtrBldgFl3 - Install Lighting &Small Power |  | 50d | 2012-02-28 | 2012-04-18 | XP341610 FS+50d, P3E09S (other project), XE401720 FS-20d, EE761700 (other project), EE76170010 (other project) FF+20d, EE76510110 (other project) FF+20d, XH00172005 SS+15d, P3E03S2 (other project) FF+20d, XC501718 | 70d | 181.5d |  | TB26 - 3 - Construction Normal 7days * CA17 | Lighting illuminates [150 pcs]; Lighting (iluminates) [1500 h] | 60,000 |  | 2011-05-10 | 2012-01-31 | E-16-03-01 | XE701720 | 1500 | 0 | 934 |  | 17 | 200 | 200 | C | LND | X | E | XE70 | 1720 | E | 16 | X | EL | LND | 1610 | 1500,00 |  |  |  |  | URMA | 2012-05-10 | 2011-08-15 | UDF_G3 |  |  |  |  |  |  |  |
| XE801720 |  | CA17 ExtrBldgFl3 - Install Heat Tracing |  | 40d | 2012-03-20 | 2012-04-28 | P3E19S (other project), E3E1950 (other project), XR401720 FS-40d, XR601720 FS-30d | 17d | 0d |  | TB26 - 3 - Construction Normal 7days * CA17 | Electrical Heat Tracing [900 m]; Electrical heat tracing [450 h] | 18,000 |  | 2011-06-20 | 2012-03-20 | E-16-04-01 | XE801720 | 450 | 0 | 934 |  | 17 | 200 | 200 | C | LND | X | E | XE80 | 1720 | E | 17 | X | HT | LND | 1720 | 450,00 | to be installed later |  |  |  | URMA | 2012-06-30 | 2011-09-15 | UDF_G2 |  |  |  |  |  | 005 |  |
| XE50172010 |  | CA17 ExtrBldgFl3 - Cable Pulling Electric Part II (over SR1708) |  | 30d | 2012-06-22 | 2012-07-27 | EE561720 (other project), P3E15AS (other project), XE501708 SS+18d, P3E15CS (other project), XE500C01, XE401720 FF+20d, P3E15BS (other project) | -58.5d | 22d |  | TB26 - V - Construct-Winter partly * | Cable Pulling [9000 m]; Cable pulling [4500 h] | 180,000 |  | 2011-05-20 | 2012-02-10 | E-16-01-01 | XE50172010 | 4500 | 0 | 934 |  | 17 | 200 | 200 | C | LND | X | E | XE50 | 1720 | E | 17 | X | EL | LND | 1720 | 4500,00 |  |  |  |  | URMA | 2012-07-01 | 2011-10-01 | UDF_G3 | m | 9250 | 2012-02-06 | 2012-03-19 |  |  |  |
| XE50172005 |  | CA17 ExtrBldgFl3 - Cable Pulling Electric Part I (over SR1707) |  | 30d | 2012-07-18 | 2012-08-22 | P3E15AS (other project), P3E15CS (other project), P3E15BS (other project), EE561720 (other project), XE500C01, XE401720 FF+20d, XE501707 FS-20d | -80.5d | 0d |  | TB26 - V - Construct-Winter partly * | Cable pulling [4500 h]; Cable Pulling [9000 m] | 180,000 |  | 2011-05-20 | 2012-02-10 | E-16-01-01 | XE50172005 | 4500 | 0 | 934 |  | 17 | 200 | 200 | C | LND | X | E | XE50 | 1720 | E | 17 | X | EL | LND | 1720 | 4500,00 |  |  |  |  | URMA | 2012-07-01 | 2011-10-01 | UDF_G3 | m | 9250 | 2011-12-20 | 2012-02-19 |  |  |  |
| XE601720 |  | CA17 ExtrBldgFl3 - Cable Termination & Testing |  | 60d | 2012-08-04 | 2012-10-03 | XE50172005 FS-15d, XE341720, XE50172010 FS-15d | -94.5d | 0d |  | TB26 - 3 - Construction Normal 7days * CA17 | Cable connecting [210 pcs]; Cable connecting [525 h] | 21,000 |  | 2011-04-20 | 2011-11-30 | E-16-02-01 | XE601720 | 525 | 0 | 934 |  | 17 | 200 | 200 | C | LND | X | E | XE60 | 1720 | E | 17 | X | ET | LND | 1720 | 525,00 |  |  |  |  | URMA | 2012-08-14 | 2011-12-10 | UDF_G3 |  |  |  |  |  |  |  |
|  | J | **Instrumentation** |  |  | 2012-02-02 | 2012-11-13 |  |  |  |  |  |  |  |  |  |  |  |  |  |  |  |  |  |  |  |  |  |  |  |  |  |  |  |  |  |  |  |  |  |  |  |  |  |  |  |  |  |  |  |  |  |  |  |
| XJ321720 |  | CA17 ExtrBldgFl3 - Install Junction Boxes |  | 40d | 2012-02-02 | 2012-03-14 | XR401720 FS-45d, XC911720, P3J06ES (other project) FS+14d, P3J06FS (other project), EJ321720 (other project), XN601720 | 5d | 0d |  | TB26 - 3 - Construction Normal 7days * CA17 | Junction Boxes/Cabinets/Panels [25 pcs]; Install Junction Boxes/ Cabinets/ Panels [625 h] | 25,000 |  | 2011-08-10 | 2012-03-30 | E-17-04-09 | XJ321720 | 625 | 0 | 934 |  | 17 | 200 | 200 | C | LND | X | J | XJ32 | 1720 | J | 17 | X | IN | LND | 1720 | 625,00 | Civil 100%, Equipment 100%, Piping 50% |  |  |  | URMA | 2012-07-20 | 2011-12-15 | UDF_G1 |  |  |  |  |  |  |  |
| XJ421720 |  | CA17 ExtrBldgFl3 - Install Secondary Cable Trays |  | 60d | 2012-02-28 | 2012-04-28 | XJ321720 FS-20d, XE401720 FS-20d, EJ46172010 (other project), XR401720 FS-45d | 0d | 5d |  | TB26 - 3 - Construction Normal 7days * CA17 | Secondary cable trays [430 m]; Install secondary cable trays [1612.5 h] | 64,500 |  | 2011-08-10 | 2011-11-30 | E-15-01-11 | XJ421720 | 1612,5 | 0 | 934 |  | 17 | 200 | 200 | C | LND | X | J | XJ42 | 1720 | J | 17 | X | IN | LND | 1720 | 1612,50 |  |  |  |  | URMA | 2012-04-01 | 2011-09-20 | UDF_G1 | m | 673 | 2011-09-30 | 2011-12-19 | x |  |  |
| XJ441720 |  | CA17 ExtrBldgFl3 - Install Conduits to Instrm |  | 50d | 2012-03-04 | 2012-04-23 | XJ321720 FS-10d, XE401720 FS-20d, XR401720 FS-45d | 5d | 10d |  | TB26 - 3 - Construction Normal 7days * CA17 |  |  |  | 2011-08-10 | 2012-03-30 | E-17-04-09 | XJ441720 | 0 | 0 | 934 |  | 17 | 200 | 200 | C | LND | X | J | XJ44 | 1720 | J | 17 | X | IN | LND | 1720 |  |  |  |  |  | URMA | 2012-07-20 | 2011-12-15 | UDF_G2 |  |  |  |  |  |  |  |
| XJ301720 |  | CA17 ExtrBldgFl3 - Install Field Instruments |  | 50d | 2012-04-04 | 2012-05-25 | EJ361720 (other project), P3J04BS (other project), XR801720 FS-25d, P3J05S (other project), XR401720 FS-45d | -8d | 0d |  | TB26 - 3 - Construction Normal 7days * CA17 | Field Instruments [40 pcs]; Install field instruments [220 h] | 8,800 |  | 2011-08-10 | 2012-03-30 | E-17-04-09 | XJ301720 | 220 | 0 | 934 |  | 17 | 200 | 200 | C | LND | X | J | XJ30 | 1720 | J | 17 | X | IN | LND | 1720 | 220,00 |  |  |  |  | URMA | 2012-07-20 | 2011-12-15 | UDF_G1 |  |  |  |  |  |  |  |
| XJ701720 |  | CA17 ExtrBldgFl3 - Instrument Tubing |  | 40d | 2012-04-29 | 2012-06-09 | XJ301720 FS-25d | 0d | 9d |  | TB26 - 3 - Construction Normal 7days * CA17 |  |  |  | 2011-08-10 | 2012-03-30 | E-17-04-09 | XJ701720 | 0 | 0 | 934 |  | 17 | 200 | 200 | C | LND | X | J | XJ70 | 1720 | J | 17 | X | IN | LND | 1720 |  |  |  |  |  | URMA | 2012-07-20 | 2011-12-15 | UDF_G2 |  |  |  |  |  |  |  |
| XJ391720 |  | CA17 ExtrBldgFl3 - Install Earthing Field Eqpt |  | 40d | 2012-05-05 | 2012-06-15 | XJ301720 FS-20d, XJ421720, XJ441720 | -5d | 4d |  | TB26 - 3 - Construction Normal 7days * CA17 |  |  |  | 2011-08-10 | 2012-03-30 | E-17-04-09 | XJ391720 | 0 | 0 | 934 |  | 17 | 200 | 200 | C | LND | X | J | XJ39 | 1720 | J | 17 | X | IN | LND | 1720 |  |  |  |  |  | URMA | 2012-07-20 | 2011-12-15 | UDF_G1 |  |  |  |  |  |  |  |
| XJ541720 |  | CA17 ExtrBldgFl3 - Pulling Singlecore Cables |  | 40d | 2012-05-26 | 2012-07-12 | EJ801720 (other project), XJ441720 FS-25d, XJ421720, XE500C01, XJ301720 | -7d | 0d |  | TB26 - V - Construct-Winter partly * | Singlecore cables [3600 m]; Pull singlecore cables [2700 h] | 108,000 |  | 2011-08-10 | 2012-03-30 | E-17-04-09 | XJ541720 | 2700 | 0 | 934 |  | 17 | 200 | 200 | C | LND | X | J | XJ54 | 1720 | J | 17 | X | IN | LND | 1720 | 2700,00 |  |  |  |  | URMA | 2012-07-20 | 2011-12-15 | UDF_G2 | m | 3430 | 2012-02-20 | 2012-04-01 |  |  |  |
| XJ641720 |  | CA17 ExtrBldgFl3 - Termin Singlecore Cables |  | 40d | 2012-06-20 | 2012-07-29 | XJ541720 FS-20d, XJ301720 FS-25d, XJ321720, XJ391720, XJ701720 | -9d | 85.5d |  | TB26 - 3 - Construction Normal 7days * CA17 | Termination Field [1413 mhr]; Termination field [1413 h] | 141,300 |  | 2011-08-10 | 2012-03-30 | E-17-04-09 | XJ641720 | 1413 | 0 | 934 |  | 17 | 200 | 200 | C | LND | X | J | XJ64 | 1720 | J | 17 | X | IN | LND | 1720 | 1413,00 |  |  |  |  | URMA | 2012-07-20 | 2011-12-15 | UDF_G2 |  |  |  |  |  |  |  |
| XJ521720 |  | CA17 ExtrBldgFl3 - Pulling Multicore Cables |  | 40d | 2012-07-16 | 2012-08-31 | XJ321720 FS-20d, XJ521707 FS-10d, XE500C01, XJ521708 FS-10d, XE401720 | -77.5d | 0d |  | TB26 - V - Construct-Winter partly * | Multicore cables [4700 m]; Pull multicore cables [2350 h] | 94,000 |  | 2011-05-20 | 2012-03-10 | E-17-01-01 | XJ521720 | 2350 | 0 | 934 |  | 17 | 200 | 200 | C | LND | X | J | XJ52 | 1720 | J | 17 | X | IN | LND | 1720 | 2350,00 |  |  |  |  | URMA | 2012-06-16 | 2011-11-01 | UDF_G2 | m | 3400 | 2012-01-26 | 2012-03-06 |  |  |  |
| XJ621720 |  | CA17 ExtrBldgFl3 - Termin Multicore Cables |  | 40d | 2012-08-20 | 2012-09-29 | XJ521720 FS-10d, XH00172005, XJ321720 | -90.62d | 3.88d |  | TB26 - 3 - Construction Normal 7days * CA17 | Termination Field [1412 mhr]; Termination field [1412 h] | 141,200 |  | 2011-05-20 | 2012-03-10 | E-17-01-01 | XJ621720 | 1412 | 0 | 934 |  | 17 | 200 | 200 | C | LND | X | J | XJ62 | 1720 | J | 17 | X | IN | LND | 1720 | 1412,00 |  |  |  |  | URMA | 2012-06-16 | 2011-11-01 | UDF_G2 |  |  |  |  |  |  |  |
| XJ801720 |  | CA17 ExtrBldgFl3 - Inspections/ Mech. Acceptance/ Loop Checks |  | 40d | 2012-10-03 | 2012-11-13 | XJ641720 FS-20d, XJ701720, XJ391720, X3J120 FF, X030410030, EJ801720 (other project), IMS-C-000420 FF, XE601720, XJ621720 | -94.5d | 22d |  | TB26 - 3 - Construction Normal 7days * CA17 | Loop Checks [220 pcs]; Loop checks [1100 h] | 44,000 |  | 2011-06-10 | 2012-04-30 | E-17-02-01 | XJ801720 | 1100 | 0 | 934 |  | 17 | 200 | 200 | C | LND | X | J | XJ80 | 1720 | J | 17 | X | LT | LND | 1720 | 1100,00 |  |  |  |  | URMA | 2012-08-18 | 2012-03-01 | UDF_G2 |  |  |  |  |  |  | 2012-08-18 |

Notes:
- XE911721: UDF_PREDECESSOR: XN30, DEL XE40, DEL XE80, DEL XJ40, Civil 100%, Equipment 100%
- XE401720: UDF_PREDECESSOR: XN30, Piping 50%
- XE341720: UDF_PREDECESSOR: XE40, Equipment 100%, Piping 50%
- XE701720: UDF_PREDECESSOR: XE40, Civil 100%, HVAC ducts, Finishing works partly
- XE801720: UDF_PREDECESSOR: XR40, Piping 50% pressure tests
- XE50172010: UDF_PREDECESSOR: XE40, XE50, DEL XE34
- XE50172005: UDF_PREDECESSOR: XE40, XE50, DEL XE34
- XE601720: UDF_PREDECESSOR: XE50, Equipment 100%
- XJ321720: UDF_PREDECESSOR: Civil 100%, Equipment 100%, Piping 50%
- XJ421720: UDF_PREDECESSOR: XE40, XJ32, Equipment 100%, Piping 50%
- XJ441720: UDF_PREDECESSOR: XE40, XJ32, XJ40, Equipment 100%, Piping 50%
- XJ301720: UDF_PREDECESSOR: XR80, XR40, Equipment 100%, Piping 50%
- XJ701720: UDF_PREDECESSOR: XJ30
- XJ391720: UDF_PREDECESSOR: XJ30, XJ42, XJ44, DEL XJ32, DEL XR40
- XJ541720: UDF_PREDECESSOR: XJ30, XJ42, XJ44
- XJ641720: UDF_PREDECESSOR: XJ30, XJ32, XJ39, XJ54, XJ70
- XJ521720: UDF_PREDECESSOR: XE40, XJ32, XJ52
- XJ621720: UDF_PREDECESSOR: XJ32, XJ52
- XJ801720: UDF_PREDECESSOR: XE60, XJ39, XJ62, XJ64, XJ70

| ID | WBS | Activity | Type | Duration | Start | Finish | Predecessors | Complete | Remaining | Planned start | Planned finish | Total float | Free float | Constraint | Calendar | Resources | Cost | TB26 Ressource Budget | UDF_SELECT | UDF_SAVE ACT ID | UDF_BUDGETED LABOR UNIT | UDF_ACTUAL LABOR UNIT | Department | Constr. Area | PMT-Area | PMT-Schedule Org | PMT-Phase | PMT-Respons. | WBS Phase | WBS Discipline | WBS Type of Work | WBS Objects | Russia WBS Discipline (Russia) | Russia Construction Area | Russia WBS Phase | IMS | UPT | Russia WBS Objects | UDF_CONTRACT FINISH DATE | UDF_CONTRACT ITEM | UDF_Text4 | UDF_CONTRACT INDICATOR | UDF_EXPECTED START | UDF_EXPECTED FINISH | UDF_SELECT UPDATE PROGRESS | UDF_CHECK BASELINE | UDF_CHECK RESOURCE DATES | Subcontractor | UDF_CHECK CRITICAL PATH | Zeigen/n. Zeigen | UDF_Concrete | Type of Work | Comments | TB26 Semantics | Inquiry/Order No |
| --- | --- | --- | --- | --- | --- | --- | --- | --- | --- | --- | --- | --- | --- | --- | --- | --- | --- | --- | --- | --- | --- | --- | --- | --- | --- | --- | --- | --- | --- | --- | --- | --- | --- | --- | --- | --- | --- | --- | --- | --- | --- | --- | --- | --- | --- | --- | --- | --- | --- | --- | --- | --- | --- | --- | --- |
|  | W | **Painting** |  |  | 2011-08-25 | 2011-11-02 |  |  |  |  |  |  |  |  |  |  |  |  |  |  |  |  |  |  |  |  |  |  |  |  |  |  |  |  |  |  |  |  |  |  |  |  |  |  |  |  |  |  |  |  |  |  |  |  |  |
| XW501720 |  | CA17 ExtrBldgFl3 - Surf.Protection Piping |  | 60d | 2011-08-25 A | 2011-11-02 | XR201720 SS |  | 58d |  |  | 426.5d |  |  |  | Piping painting [1056 sqm]; Piping painting [2640 h] | 1,921.63 | 2640,00 | OMUS-1 | XW501720 | 2640 | 0 | 934 | 17 | 200 | 200 | C | LND | X | W | XW50 | 1720 | W | 17 | X | PA | LND | 1720 |  |  |  |  |  |  |  |  |  |  |  |  |  |  |  |  |  |
|  | V | **Insulation** |  |  | 2012-04-09 | 2012-08-07 |  |  |  |  |  |  |  |  |  |  |  |  |  |  |  |  |  |  |  |  |  |  |  |  |  |  |  |  |  |  |  |  |  |  |  |  |  |  |  |  |  |  |  |  |  |  |  |  |  |
| XV301720 |  | CA17 ExtrBldgFl3 - Insulation Equipment |  | 100d | 2012-04-09 | 2012-07-20 | XE801720 SS+20d |  |  |  |  | 17d | 0d |  | TB26 - 3 - Construction Normal 7days * CA17 | Equipment insulation [350 sqm]; Equipment insulation [4375 h] | 1,370.27 | 4375,00 | OMUS-1 | XV301720 | 4375 | 0 | 934 | 17 | 200 | 200 | C | LND | X | V | XV30 | 1720 | V | 17 | X | INS | LND | 1720 | 2012-03-30 | E-13-03 |  |  |  |  |  |  |  |  |  |  |  |  |  |  |  |
| XV501720 |  | CA17 ExtrBldgFl3 - Insulation Piping |  | 100d | 2012-04-27 | 2012-08-07 | XE801720 FF+20d, XR601720 SS+12d, XV301720 FF+18d |  |  |  |  | 17d | 128.5d |  | TB26 - 3 - Construction Normal 7days * CA17 | Piping insulation [950 sqm]; Piping insulation [7125 h] | 5,475.16 | 7125,00 | OMUS-1 | XV501720 | 7125 | 0 | 934 | 17 | 200 | 200 | C | LND | X | V | XV50 | 1720 | V | 17 | X | INS | LND | 1720 | 2012-04-30 | E-13-01 |  |  |  |  |  |  |  |  |  |  |  |  |  |  |  |
|  | 30 | **CA17 - Extrusion Bldg 4th Floor +25,35m** |  |  | 2011-04-10 | 2012-11-19 |  |  |  |  |  |  |  |  |  |  |  |  |  |  |  |  |  |  |  |  |  |  |  |  |  |  |  |  |  |  |  |  |  |  |  |  |  |  |  |  |  |  |  |  |  |  |  |  |  |
|  | C | **Civil Work** |  |  | 2011-08-21 | 2012-03-23 |  |  |  |  |  |  |  |  |  |  |  |  |  |  |  |  |  |  |  |  |  |  |  |  |  |  |  |  |  |  |  |  |  |  |  |  |  |  |  |  |  |  |  |  |  |  |  |  |  |
| XC40173030 |  | CA17 ExtrBldgFl4 - Concrete Works Stairtowers North <30m (D-E/1-2) |  | 29d | 2011-08-21 A | 2011-09-10 | XC40172030 |  | 15d | 2011-08-21 | 2011-09-18 | -95d | 0d |  | TB26 - 3 - Construction Normal 7days * CA17 | Concrete works [105 cbm]; Concrete works [3150 h] | 21,123.14 | 12300,00 |  | XC40173010 | 3150 | 0 | 934 | 17 | 200 | 200 | C | MO04 | X | C | XC40 | 1730 | C | 17 | X | EB | LND | 1730 |  |  | CA17 - critical - CW5 | UDF_G4 | 2011-08-05 | 2011-09-02 | 27.8. | x | x | MO11 |  |  |  |  |  |  |  |
| XC40173040 |  | CA17 ExtrBldgFl4 - Concrete Works Stairtowers South <30m (D-E/4-5) |  | 27d | 2011-08-21 A | 2011-09-10 | XC40172040 |  | 15d | 2011-08-21 | 2011-09-16 | 477.5d | 0d |  | TB26 - 3 - Construction Normal 7days * CA17 | Concrete works [138 cbm]; Concrete works [4140 h] | 21,123.14 | 12300,00 |  | XC40173010 | 4140 | 0 | 934 | 17 | 200 | 200 | C | MO04 | X | C | XC40 | 1730 | C | 17 | X | EB | LND | 1730 |  |  | CA17 - critical - CW5 | UDF_G4 | 2011-08-15 | 2011-09-10 | 27.8. | x | x | MO11 |  |  |  |  |  |  |  |
| XC40173005 |  | CA17 ExtrBldgFl4 - Precast Concrete Elements Stairtowers <30m North/South |  | 30d | 2011-10-12 | 2011-11-11 | EC48173010 (other project), IMS-C-000020 FF |  |  |  |  | -16d | 0d | as late as possible | TB26 - 3 - Construction Normal 7days * CA17 |  |  |  |  | XC40173005 | 0 | 0 | 934 | 17 | 200 | 200 | C | MO04 | X | C | XC40 | 1730 | C | 17 | X | pre | LND | 1730 |  |  | CA17 - critical - CW5 |  |  |  |  | x |  | MO11 |  |  |  |  |  |  |  |
| XC40173010 |  | CA17 ExtrBldgFl4 - Concrete Works Col/Wal <30m (A-F/1-5) |  | 20d | 2011-10-22 | 2011-11-11 | XC40172020, XC40172010 FS-10d |  |  |  |  | -16d | 0d |  | TB26 - 3 - Construction Normal 7days * CA17 | Concrete works [167 cbm]; Concrete works [5010 h] | 21,123.14 | 12300,00 |  | XC40173010 | 5010 | 0 | 934 | 17 | 200 | 200 | C | MO04 | X | C | XC40 | 1730 | C | 17 | X | EB | LND | 1730 |  |  | CA17 - critical - CW5 |  |  |  |  | x |  | MO11 |  |  |  |  |  |  |  |
| XC40173015 |  | CA17 ExtrBldgFl4 - Erection Precast Elements Stairtowers <30m North/South |  | 10d | 2011-11-12 | 2011-11-21 | XC40173010, XC40173005, XC40172015 |  |  |  |  | -16d | 29d |  | TB26 - 3 - Construction Normal 7days * CA17 | Precast Concrete Works [60 cbm]; Precast concrete works [150 h] | 6,000 | 150,00 |  | XC40173015 | 150 | 0 | 934 | 17 | 200 | 200 | C | CiC | X | C | XC40 | 1730 | C | 17 | X | EB | LND | 1730 |  |  | CA17 - critical - CW5 |  |  |  |  | x |  | MO11 |  |  |  |  |  |  |  |
| XC40173020 |  | CA17 ExtrBldgFl4 - Concrete Works Ceiling/Roof +30m |  | 20d | 2011-12-06 | 2011-12-25 | EC48173020 (other project), XN201730 FS-10d, IMS-C-000080 FF |  |  |  |  | -161d | 0d |  | TB26 - 3 - Construction Normal 7days * CA17 | Concrete works [630 cbm]; Concrete works [18900 h] | 8,011.71 | 18900,00 |  | XC40173020 | 18900 | 0 | 934 | 17 | 200 | 200 | C | MO04 | X | C | XC40 | 1730 | C | 17 | X | EB | LND | 1730 |  |  | CA17 - critical - CW5 |  |  |  |  |  |  | MO11 | OD 25>20 | C9-1 |  |  |  |  |  |
| XC501730 |  | CA17 ExtrBldgFl4 - Finishing Works Rooms |  | 80d | 2011-12-26 | 2012-03-23 | XC40173020, EC501710 (other project) FS+20d, P3S09S (other project) FF+10d, IMS-C-000080 FF, XC510C00 FS+15d, P3S06S (other project) FF+20d |  |  |  |  | 6d | 0d |  | TB26 - 3 - Construction Normal 7days * CA17 | Finishing Works - Extrusion Building CA17 [33593 mhr]; Finishing Works - Extrusion building CA17 [33593 h] | 3,359,300 | 33593,00 | XC50 | XC501730 | 33593 | 0 | 934 | 17 | 200 | 200 | C | CiC | X | C | XC50 | 1730 | C | 17 | X | EB | LND | 1710 |  |  | CA17 - critical - CW5 |  |  |  |  |  |  |  | OD 120>80 |  | 1 |  |  |  |  |
| XC501730_1 |  | CA17 ExtrBldgFl4 - Plastering and Painting |  | 20d | 2011-12-26 | 2012-01-21 | XC501730 SS |  |  |  |  | 6d | 0d |  | TB26 - 3 - Construction Normal 7days * CA17 |  |  | 33593,00 |  | XC501730 | 33593 | 0 | 934 | 17 | 200 | 200 | C | CiC | X | C | XC50 | 1730 | C | 17 | X | EB | LND | 1710 |  |  | CA17 - critical - CW5 |  |  |  |  |  |  |  | OD 120>80 |  | 1 |  |  |  |  |
|  | N | **Structural Steel** |  |  | 2011-04-10 | 2012-02-20 |  |  |  |  |  |  |  |  |  |  |  |  |  |  |  |  |  |  |  |  |  |  |  |  |  |  |  |  |  |  |  |  |  |  |  |  |  |  |  |  |  |  |  |  |  |  |  |  |  |
| XN801701 |  | CA17 ExtrBldgFl4 SK1701 - KMD Assy Drawings level 123 m | milestone | 0d | 2011-04-10 A | 2011-04-10 A |  | 100% |  |  |  |  |  | finish on 2011-04-10 | TB26 - 3 - Construction Normal 7days * CA17 |  |  | 22t |  | XN801701 | 0 | 0 | 934 | 17 | 200 | 200 | C | LND | X | N | XN05 | 1730 | N | 17 | X | SS | LND | 1730 |  |  |  |  |  |  |  |  |  |  |  | KMD |  | XNK |  |  |  |
| XN811701 |  | CA17 ExtrBldgFl4 SK1701- Steel Deliveries level 123 m | milestone | 0d | 2011-04-19 A | 2011-04-19 A |  | 100% |  |  |  |  |  | finish on 2011-04-18 | TB26 - 3 - Construction Normal 7days * CA17 |  |  | 22t |  | XN811701 | 0 | 0 | 934 | 17 | 200 | 200 | C | LND | X | N | XN06 | 1730 | N | 17 | X | SS | LND | 1730 |  |  |  |  |  |  |  |  |  |  |  | SD |  | XNK |  |  |  |
| XN201730 |  | CA17 ExtrBldgFl4 SK1701- Erec Prim Steel+M.Sheets <30m |  | 40d | 2011-11-06 | 2011-12-15 | XN811701 FS+10d, XN801701, P3N024N (other project), XC40171813 FF, XC40172020 FS-20d, XN201720 |  |  |  |  | -161d | 0d |  | TB26 - 3 - Construction Normal 7days * CA17 | Piperacks, Main Structures [522 t]; Piperacks, Main structures [22185 h] | 4,966.67 | 22185,00 |  | XN201730 | 22185 | 0 | 934 | 17 | 200 | 200 | C | LND | X | N | XN20 | 1730 | N | 17 | X | SS | LND | 1730 |  | E-04-15 | CA17 - critical - CW5 |  |  |  |  |  |  | ChSK |  | C9-1 |  | PU10 | CA17 Heavy Lift | t | 2DC8990 |
| XN801730 |  | CA17 ExtrBldgFl4 SK1701- Install Cladding |  | 70d | 2011-11-26 | 2012-02-10 | P3N02§N (other project), XN201730 SS+20d, P3N03N (other project), EN801711 (other project) |  |  |  |  | -25d | 10d |  | TB26 - 3 - Construction Normal 7days * CA17 | Cladding [1380 sqm]; Cladding [6900 h] | 2,266.04 | 6900,00 |  | XN801730 | 6900 | 0 | 934 | 17 | 200 | 200 | C | LND | X | N | XN80 | 1730 | N | 17 | X | SS | LND | 1730 |  |  |  |  |  |  |  |  |  | ChSK |  |  |  | XNK |  |  |  |
| XN301730 |  | CA17 ExtrBldgFl4 SK1701 - Install Eqpt Platforms |  | 40d | 2011-12-16 | 2012-01-31 | P3N024N (other project), XN201730 |  |  |  |  | -35d | 0d |  | TB26 - 3 - Construction Normal 7days * CA17 | Ladders & platforms | 1,123.41 | 0,00 |  | XN301730 | 0 | 0 | 934 | 17 | 200 | 200 | C | LND | X | N | XN30 | 1730 | N | 17 | X | SS | LND | 1730 |  |  |  |  |  |  |  |  |  | ChSK |  |  |  | XNK |  | t |  |
| XN401730 |  | CA17 ExtrBldgFl4 SK1701 - Install Railings,Ladders,etc. |  | 40d | 2011-12-24 | 2012-02-08 | XN301730 FF+8d, XN201730 SS+20d |  |  |  |  | -13d | 0d |  | TB26 - 3 - Construction Normal 7days * CA17 | Ladders & platforms | 155.21 | 0,00 |  | XN401730 | 0 | 0 | 934 | 17 | 200 | 200 | C | LND | X | N | XN40 | 1730 | N | 17 | X | SS | LND | 1730 |  |  |  |  |  |  |  |  |  | ChSK |  |  |  | XNK |  |  |  |
| XC701730 |  | CA17 ExtrBldgFl4 SK1701 - Install Supports Ceiling <30m |  | 50d | 2011-12-26 | 2012-02-20 | XC40173020, P3N024N (other project) |  |  |  |  | -10d | 25d |  | TB26 - 3 - Construction Normal 7days * CA17 | Piperacks, Main Structures [36 t]; Piperacks, Main structures [1530 h] |  | 1530,00 |  | XC701730 | 1530 | 0 | 934 | 17 | 200 | 200 | C | LND | X | C | XN70 | 1730 | N | 17 | X | SS | LND | 1730 |  |  | CA17 - critical - CW5 |  |  |  |  |  |  | MO11 |  |  |  | XNK |  |  |  |
| XN601730 |  | CA17 ExtrBldgFl4 SK1701 - Install Gratings |  | 40d | 2011-12-29 | 2012-02-13 | PN691730 (other project), XN401730 FF+5d |  |  |  |  | -13d | 0d |  | TB26 - 3 - Construction Normal 7days * CA17 | Grating [300 sqm]; Grating [1125 h] | 8,639.94 | 1125,00 |  | XN601730 | 1125 | 0 | 934 | 17 | 200 | 200 | C | LND | X | N | XN60 | 1730 | N | 17 | X | SS | LND | 1730 |  |  |  |  |  |  |  |  |  | ChSK |  |  |  | XNK |  |  |  |

Notes:
- XW501720: P3 Activity Log Info: Clarification Surface Protection during Prefab
- XN811701: Scope: 09.02.2011: 500 ton
- XN201730: Scope: 15.02.2011 (O.Siegel): die Liefermenge fьr Level 123m / belдuft sich auf 500 t. Da die Eqpt-Platforms 40 t wiegen, Support / Ceiling 30t wiegt, bleiben fьr Prim Steel 430 t.
- XN301730: Scope: 15.02.2011 (O.Siegel): die Liefermenge fьr Level 123m / belдuft sich auf 500 t. Da die Eqpt-Platforms 40 t wiegen, Support / Ceiling 30t wiegt, bleiben fьr Prim Steel 430 t.
- XC701730: Scope: 15.02.2011 (O.Siegel): die Liefermenge fьr Level 123m / belдuft sich auf 500 t. Da die Eqpt-Platforms 40 t wiegen, Support / Ceiling 30t wiegt, bleiben fьr Prim Steel 430 t.

| ID | WBS | Activity | Type | Duration | Start | Finish | Predecessors | Total float | Free float | Constraint | Calendar | Resources | Cost | TB26 Ressource Budget | UDF_SELECT | UDF_Text4 | UDF_CONTRACT START DATE | UDF_CONTRACT FINISH DATE | UDF_CONTRACT DATE PENALIZED | UDF_CHECK CRITICAL PATH | UDF_L3 START DATE | UDF_L3 FINISH DATE | UDF_SAVE ACT ID | UDF_BUDGETED LABOR UNIT | UDF_ACTUAL LABOR UNIT | Department | Type of Work | Constr. Area | PMT-Area | PMT-Schedule Org | PMT-Phase | PMT-Respons. | WBS Phase | WBS Discipline | WBS Type of Work | WBS Objects | Russia WBS Discipline (Russia) | Russia Construction Area | Russia WBS Phase | IMS | UPT | Russia WBS Objects | Subcontractor | WEIGHT | UDF_PO No | UDF_TAG No | UDF_Object No | UDF_PACKAGE | UDF_SUPPLIER | UDF_Vendor Representatives | Zeigen/n. Zeigen | UDF_LEVEL | UDF_Weight (ton) | POSITION | UDF_CONTRACT ITEM | Inquiry/Order No |
| --- | --- | --- | --- | --- | --- | --- | --- | --- | --- | --- | --- | --- | --- | --- | --- | --- | --- | --- | --- | --- | --- | --- | --- | --- | --- | --- | --- | --- | --- | --- | --- | --- | --- | --- | --- | --- | --- | --- | --- | --- | --- | --- | --- | --- | --- | --- | --- | --- | --- | --- | --- | --- | --- | --- | --- | --- |
|  | H | **HVAC** |  |  | 2012-01-22 | 2012-07-09 |  |  |  |  |  |  |  |  |  |  |  |  |  |  |  |  |  |  |  |  |  |  |  |  |  |  |  |  |  |  |  |  |  |  |  |  |  |  |  |  |  |  |  |  |  |  |  |  |  |  |
| XH00173005 |  | CA17 ExtrBldgFl4 - Installation HVAC |  | 80d | 2012-01-22 | 2012-04-12 | XH000000 FF, EH30173005 (other project), XC701730 FF+10d, XN801730 FF+10d, XC40173020, P3H01SL (other project), XC501730_1 | 6d | 0d |  | TB26 - 3 - Construction Normal 7days * CA17 | HVAC - Extrusion Building CA17 [10282 mhr]; HVAC - Extrusion building CA17 [10282 h] |  | 10282,00 | REL XC50 | CA17 - critical - CW5 | 2011-11-10 | 2011-11-10 | P | OD 100>80 | 2011-07-13 | 2011-10-03 | XH00173005 | 10282 | 0 | 934 | XBB | 17 | 200 | 200 | C | LND | X | H | XH00 | 1700 | H | 17 | X | hvac | LND | 1730 | ARMO |  |  |  |  |  |  |  |  |  |  |  |  |  |
| XH00173010 |  | CA17 ExtrBldgFl4 - Testing/Commissiong HVAC (Start w. temp. Power) |  | 85d | 2012-04-13 | 2012-07-09 | XH00173005, XH000C10, X0300008 FS+20d | 6d | 0d |  | TB26 - 3 - Construction Normal 7days * CA17 |  |  |  |  | CA17 - critical - CW5 | 2011-12-30 | 2011-12-30 | P |  | 2011-10-03 | 2011-12-12 | XH00173010 | 0 | 0 | 934 | XBB | 17 | 200 | 200 | C | LND | X | H | XH20 | 1730 | H | 17 | X | hvac | LND | 1730 | ARMO |  |  |  |  |  |  |  |  |  |  |  |  |  |
| XH00173007 |  | CA17 ExtrBldgFl4 - HVAC ready for Heating | milestone | 0d | 2012-04-23 | 2012-04-23 | XH00173010 SS+10d, XC501730 | 338.5d | 131.5d |  | TB26 - 3 - Construction Normal 7days * CA17 |  |  | 4113 |  | CA17 - critical - CW5 |  |  |  |  | 2011-10-13 | 2011-10-13 | XH00173007 | 0 | 0 | 934 | XBB | 17 | 200 | 200 | C | LND | X | H | XH00 | 1730 | H | 17 | X | hvac | LND | 1730 | ARMO |  |  |  |  |  |  |  |  |  |  |  |  |  |
|  | U | **Package Units** |  |  |  |  |  |  |  |  |  |  |  |  |  |  |  |  |  |  |  |  |  |  |  |  |  |  |  |  |  |  |  |  |  |  |  |  |  |  |  |  |  |  |  |  |  |  |  |  |  |  |  |  |  |  |
|  | B | **Mechanical - Stationary Equipment** |  |  | 2011-09-26 | 2012-04-03 |  |  |  |  |  |  |  |  |  |  |  |  |  |  |  |  |  |  |  |  |  |  |  |  |  |  |  |  |  |  |  |  |  |  |  |  |  |  |  |  |  |  |  |  |  |  |  |  |  |  |
| PK-22452 |  | VACUUM CLEANING SYSTEM |  | 4d | 2011-09-26 | 2011-09-29 |  | 455.5d |  | start on or after 2011-09-26 |  | Static Equipment < 10 tons; Static equipment < 10t |  | 0,00 |  |  |  |  |  |  |  |  | PK-22452 | 0 | 0 |  |  | 17 |  |  |  |  | X | B |  | 1700 |  |  |  |  |  |  |  | 2200 | 2 DC 8990/ 4 | PK-22452 | SK1730 | PU22 VENT COLLECTION AND VACUUM SYSTEM | Zeppelin | Zeppelin | EQ |  |  |  |  |  |
| RF-22434 |  | BAG UNLOADING OUTLET ROTARY VALVE |  | 0d | 2011-09-26 | 2011-09-26 |  | 459.5d |  | start on or after 2011-09-26 |  | Static Equipment < 10 tons [0.38 t]; Static equipment < 10t [38 h] | 1,520 | 38,00 |  |  |  |  |  |  |  |  | RF-22434 | 38 | 0 |  |  | 17 |  |  |  |  | X | B |  | 1700 |  |  |  |  |  |  |  | 2200 | 2 DC 8990/ 4 | RF-22434 | SK1730 | PU10 CONVEYING SYSTEM (PK-21501) ZEPPELIN | Zeppelin | Zeppelin | EQ | structure +19.315 |  |  |  |  |
| RF-22435 |  | OUTLET ROTARY VALVE |  | 0d | 2011-09-26 | 2011-09-26 |  | 459.5d |  | start on or after 2011-09-26 |  | Static Equipment < 10 tons [0.38 t]; Static equipment < 10t [38 h] | 1,520 | 38,00 |  |  |  |  |  |  |  |  | RF-22435 | 38 | 0 |  |  | 17 |  |  |  |  | X | B |  | 1700 |  |  |  |  |  |  |  | 2200 | 2 DC 8990/ 4 | RF-22435 | SK1730 | PU10 CONVEYING SYSTEM (PK-21501) ZEPPELIN | Zeppelin | Zeppelin | EQ |  |  |  |  |  |
| RF-22436 |  | OUTLET ROTARY VALVE |  | 0d | 2011-09-26 | 2011-09-26 |  | 459.5d |  | start on or after 2011-09-26 |  | Static Equipment < 10 tons [0.23 t]; Static equipment < 10t [23 h] | 920 | 23,00 |  |  |  |  |  |  |  |  | RF-22436 | 23 | 0 |  |  | 17 |  |  |  |  | X | B |  | 1700 |  |  |  |  |  |  |  | 2200 | 2 DC 8990/ 4 | RF-22436 | SK1730 | PU10 CONVEYING SYSTEM (PK-21501) ZEPPELIN | Zeppelin | Zeppelin | EQ | structure +19.315 |  |  |  |  |
| HP-21441 |  | PREBLEND PELLETS SURGE |  | 10d | 2011-11-18 | 2011-11-29 | HP-21401, HP-21405, XB001720 FF, XN201720 SS+20d, P3U10S1D (other project), XB001720 SS | 60d | 0d |  |  | Static Equipment < 10 tons [2.2 t]; Static equipment < 10t [220 h] | 8,800 | 220,00 |  |  |  |  |  |  |  |  | HP-21441 | 220 | 0 |  |  | 17 |  |  |  |  | X | B |  | 1720 |  |  |  |  |  |  |  | 2200 | 2 DC 8990/ 4 | HP-21441 | SK1730 | PU10 CONVEYING SYSTEM (PK-21501) ZEPPELIN | Zeppelin | Zeppelin | EQ | structure +19.015 | 2,2 | a |  |  |
| HP-22441 |  | PREBLEND PELLETS SURGE |  | 10d | 2011-11-18 | 2011-11-29 | XN201720 SS+20d, HP-21441 SS, P3U10S2A (other project), XB001720 FF, XB001720 SS, HP-22401, HP-22405 | 60d | 66.88d |  |  | Static equipment < 10t [220 h]; Static Equipment < 10 tons [2.2 t] | 8,800 | 220,00 |  |  |  |  |  |  |  |  | HP-22441 | 220 | 0 |  |  | 17 |  |  |  |  | X | B |  | 1720 |  |  |  |  |  |  |  | 2200 | 2 DC 8990/ 4 | HP-22441 | SK1730 | PU10 CONVEYING SYSTEM (PK-21501) ZEPPELIN | Zeppelin | Zeppelin | EQ | structure +19.015 | 2,2 | a |  |  |
| RF-21436 |  | OUTLET ROTARY VALVE |  | 10d | 2011-11-26 | 2011-12-07 | XC40171820, XN301718, BL-21402A/B SS, RF-21432, XC40171820 FF, RF-21431, P3U10S1D (other project) | 62d | 4d |  |  | Static Equipment < 10 tons [0.23 t]; Static equipment < 10t [23 h] | 920 | 23,00 |  |  |  |  |  |  |  |  | RF-21436 | 23 | 0 |  |  | 17 |  |  |  |  | X | B |  | 1718 |  |  |  |  |  |  |  | 2200 | 2 DC 8990/ 4 | RF-21436 | SK1730 | PU10 CONVEYING SYSTEM (PK-21501) ZEPPELIN | Zeppelin | Zeppelin | EQ | structure +15.915 | 0,23 | a |  |  |
| SL-21402 |  | RETURN PELLETS SILO (1 common for both lines) |  | 10d | 2011-11-26 | 2011-12-07 | XN201730 SS+20d, P3U10S2D (other project) | 51d | 81d |  |  | Static Equipment < 10 tons [2 t]; Static equipment < 10t [200 h] | 8,000 | 200,00 |  |  |  |  |  |  |  |  | SL-21402 | 200 | 0 |  |  | 17 |  |  |  |  | X | B |  | 1730 |  |  |  |  |  |  |  | 2000 |  | SL-21402 | SK1730 | PU10 CONVEYING SYSTEM (PK-21501) ZEPPELIN |  |  | EQ | structrue +25.35 | 2 | a |  |  |
| XB001730 |  | CA17 ExtrBldgFl4 - Install Static Eqpt | level of effort | 107d | 2011-11-26 | 2012-03-20 | F-21408 FF, F-22404 SS, RF-22402 SS, F-21402 SS, RF-21407 SS, RF-22405 SS, RF-22401 SS, F-21404 FF, F-21404 SS, F-21408 SS, F-22403 FF, F-22404 FF, F-21401 SS, RF-22405 FF, RF-22404 FF, RF-21408 FF, RF-21404 FF, F-21403 FF, F-21403 SS, XX-22401 SS, RF-21403 FF, F-22405 FF, RF-21404 SS, XX-22401 FF, F-21402 FF, RF-21405 FF, RF-22404 SS, RF-21408 SS, RF-21402 FF, F-21452 FF, F-21452 SS, F-22401 FF, RF-21402 SS, F-22407 FF, F-22401 SS, F-22402 FF, F-22402 SS, RF-22403 FF, RF-22403 SS, RF-22407 FF, F-22405 SS, BL-21452 SS, SL-21402 FF, SL-21402 SS, F-22403 SS, F-21407 FF, F-21407 SS, RF-22401 FF, RF-21401 SS, F-22407 SS, BL-21452 FF, XX-21401 SS, XX-21401 FF, RF-21403 SS, RF-22402 FF, RF-22407 SS, F-21401 FF, RF-21407 FF, RF-21405 SS, F-21405 SS, F-21405 FF, RF-21401 FF | -36d | 0d |  | TB26 - 3 - Construction Normal 7days * CA17 | Extruder |  | 48,70 | OMUS-1 |  | 2011-06-30 | 2011-09-20 |  |  |  |  | XB001730 | 0 | 0 | 934 | PU10 | 17 | 200 | 200 | C | LND | X | B | XB00 | 1710 | B | 17 | X | EQ | LND | 1730 |  |  |  |  |  |  |  |  |  |  |  |  | E-08-01-15 | 2DC8990 |
| XX-21401 |  | PELLET MASS FLOW METER |  | 5d | 2011-12-26 | 2011-12-30 | XC40173020, XC40173605, P3U02S1 (other project) | 17.38d | 60d |  |  | Static Equipment < 10 tons [0.4 t]; Static equipment < 10t [40 h] | 1,600 | 40,00 |  |  |  |  |  |  |  |  | XX-21401 | 40 | 0 |  |  | 17 |  |  |  |  | X | B |  | 1730 |  |  |  |  |  |  |  | 400 |  | XX-21401 | SK1730 | PU02 ADDITIVE SYSTEM COMPONENTS (PK-21-/22401) |  |  | EQ | structure +25.35 | 0,4 | a |  |  |
| XX-22401 |  | PELLET MASS FLOW METER |  | 5d | 2011-12-26 | 2011-12-30 | XC40173020, XC40173605, P3U02S1 (other project) | 31d | 61d |  |  | Static Equipment < 10 tons [0.4 t]; Static equipment < 10t [40 h] | 1,600 | 40,00 |  |  |  |  |  |  |  |  | XX-22401 | 40 | 0 |  |  | 17 |  |  |  |  | X | B |  | 1730 |  |  |  |  |  |  |  | 400 |  | XX-22401 | SK1730 | PU02 ADDITIVE SYSTEM COMPONENTS (PK-21-/22401) |  |  | EQ | structure +25.35 | 0,4 | a |  |  |
| F-22401 |  | ADDITIVE HOPPER SOCK FILTER |  | 10d | 2012-02-01 | 2012-02-11 | XN301730, XC40173020, P3U02S1 (other project), HP-22401 | 0d | 30d |  |  | Static Equipment < 10 tons [0.04 t]; Static equipment < 10t [4 h] | 160 | 4,00 |  |  |  |  |  |  |  |  | F-22401 | 4 | 0 |  |  | 17 |  |  |  |  | X | B |  | 1730 |  |  |  |  |  |  |  | 400 |  | F-21401 | SK1730 | PU02 ADDITIVE SYSTEM COMPONENTS (PK-21-/22401) |  |  | EQ | at HP-22401 +26.750 | 0,04 | a |  |  |
| SE-21402 |  | PELLET CLASSIFIER |  | 20d | 2012-02-01 | 2012-02-24 | SE-22402 SS, XB001736 FF, XN301730, XN201736, XB001736 SS, P3M01SA (other project), P3M01SC (other project), P3M01SB (other project) | -30d | 0d |  |  | Extruder [52 mhr]; Extruder [52 h] | 5,200 | 52,00 |  |  |  |  |  |  |  |  | SE-21402 | 52 | 0 |  |  | 17 |  |  |  |  | X | B |  | 1710 |  |  |  |  |  |  |  | 5200 |  | SE-21402 | SK1730 | M01 EXTRUDER (EX-21-/22401) |  |  | EQ | structure +29.450 | 5,2 | a |  |  |
| SE-22402 |  | PELLET CLASSIFIER |  | 20d | 2012-02-01 | 2012-02-24 | XN201736, XB001736 SS, P3M01SC (other project), P3M01SB (other project), XN301730, P3M01SA (other project), XB001736 FF | -30d | 0d |  |  | Extruder [52 h]; Extruder [52 mhr] | 5,200 | 52,00 |  |  |  |  |  |  |  |  | SE-22402 | 52 | 0 |  |  | 17 |  |  |  |  | X | B |  | 1710 |  |  |  |  |  |  |  | 5200 |  | SE-22402 | SK1730 | M01 EXTRUDER (EX-21-/22401) |  |  | EQ | structure +29.450 | 5,2 | a |  |  |
| RF-21401 |  | ADDITIVE UNLOADING STATION OUTLET FEEDER |  | 10d | 2012-02-02 | 2012-02-14 | P3U02S1 (other project), BG-21401, XC40173020 | -1.88d | 28.12d |  |  | Static equipment < 10t [9.5 h]; Static Equipment < 10 tons [0.1 t] | 380 | 9,50 |  |  |  |  |  |  |  |  | RF-21401 | 9,5 | 0 |  |  | 17 |  |  |  |  | X | B |  | 1730 |  |  |  |  |  |  |  | 400 |  | RF-21401 | SK1730 | PU02 ADDITIVE SYSTEM COMPONENTS (PK-21-/22401) |  |  | EQ | at BG-21401 +30.00 | 0,095 | a |  |  |
| RF-21402 |  | ADDITIVE UNLOADING STATION OUTLET FEEDER |  | 10d | 2012-02-02 | 2012-02-14 | BG-21402, XC40173020, P3U02S1 (other project) | -1.88d | 0d |  |  | Static Equipment < 10 tons [0.1 t]; Static equipment < 10t [9.5 h] | 380 | 9,50 |  |  |  |  |  |  |  |  | RF-21402 | 9,5 | 0 |  |  | 17 |  |  |  |  | X | B |  | 1730 |  |  |  |  |  |  |  | 400 |  | RF-21402 | SK1730 | PU02 ADDITIVE SYSTEM COMPONENTS (PK-21-/22401) |  |  | EQ | at BG-21402 +30.00 | 0,095 | a |  |  |
| RF-21403 |  | ADDITIVE UNLOADING STATION OUTLET FEEDER |  | 10d | 2012-02-02 | 2012-02-14 | XC40173020, P3U02S1 (other project), BG-21403 | -1.88d | 28.12d |  |  | Static Equipment < 10 tons [0.1 t]; Static equipment < 10t [9.5 h] | 380 | 9,50 |  |  |  |  |  |  |  |  | RF-21403 | 9,5 | 0 |  |  | 17 |  |  |  |  | X | B |  | 1730 |  |  |  |  |  |  |  | 400 |  | RF-21403 | SK1730 | PU02 ADDITIVE SYSTEM COMPONENTS (PK-21-/22401) |  |  | EQ | at BG-21403 +30.00 | 0,095 | a |  |  |
| RF-21404 |  | PEROXIDE UNLOADING STATION OUTLET FEEDER |  | 10d | 2012-02-02 | 2012-02-14 | XC40173020, P3U02S1 (other project), BG-21404 | -1.88d | 28.12d |  |  | Static Equipment < 10 tons [0.1 t]; Static equipment < 10t [9.5 h] | 380 | 9,50 |  |  |  |  |  |  |  |  | RF-21404 | 9,5 | 0 |  |  | 17 |  |  |  |  | X | B |  | 1730 |  |  |  |  |  |  |  | 400 |  | RF-21404 | SK1730 | PU02 ADDITIVE SYSTEM COMPONENTS (PK-21-/22401) |  |  | EQ | at BG-21404 +30.00 | 0,095 | a |  |  |
| RF-21405 |  | ADDITIVE UNLOADING STATION OUTLET FEEDER |  | 10d | 2012-02-02 | 2012-02-14 | BG-21405, XC40173020, P3U02S1 (other project) | -1.88d | 28.12d |  |  | Static Equipment < 10 tons [0.1 t]; Static equipment < 10t [9.5 h] | 380 | 9,50 |  |  |  |  |  |  |  |  | RF-21405 | 9,5 | 0 |  |  | 17 |  |  |  |  | X | B |  | 1730 |  |  |  |  |  |  |  | 400 |  | RF-21405 | SK1730 | PU02 ADDITIVE SYSTEM COMPONENTS (PK-21-/22401) |  |  | EQ | at BG-21405 +30.00 | 0,095 | a |  |  |
| RF-21407 |  | ADDITIVE UNLOADING STATION OUTLET FEEDER |  | 10d | 2012-02-02 | 2012-02-14 | BG-21407, P3U02S1 (other project), XC40173020 | -1.88d | 28.12d |  |  | Static Equipment < 10 tons [0.1 t]; Static equipment < 10t [9.5 h] | 380 | 9,50 |  |  |  |  |  |  |  |  | RF-21407 | 9,5 | 0 |  |  | 17 |  |  |  |  | X | B |  | 1730 |  |  |  |  |  |  |  | 400 |  | RF-21407 | SK1730 | PU02 ADDITIVE SYSTEM COMPONENTS (PK-21-/22401) |  |  | EQ | at BG-21407 +30.00 | 0,095 | a |  |  |
| RF-21408 |  | TALC UNLOADING STATION OUTLET FEEDER |  | 10d | 2012-02-02 | 2012-02-14 | XC40173020, P3U02S1 (other project), BG-21408 | -1.88d | 28.12d |  |  | Static equipment < 10t [9.5 h]; Static Equipment < 10 tons [0.1 t] | 380 | 9,50 |  |  |  |  |  |  |  |  | RF-21408 | 9,5 | 0 |  |  | 17 |  |  |  |  | X | B |  | 1730 |  |  |  |  |  |  |  | 400 |  | RF-21408 | SK1730 | PU02 ADDITIVE SYSTEM COMPONENTS (PK-21-/22401) |  |  | EQ | at BG-21408 +30.00 | 0,095 | a |  |  |
| RF-22401 |  | ADDITIVE UNLOADING STATION OUTLET FEEDER |  | 10d | 2012-02-02 | 2012-02-14 | XC40173020, BG-22401, P3U02S1 (other project) | -1.88d | 28.12d |  |  | Static Equipment < 10 tons [0.1 t]; Static equipment < 10t [9.5 h] | 380 | 9,50 |  |  |  |  |  |  |  |  | RF-22401 | 9,5 | 0 |  |  | 17 |  |  |  |  | X | B |  | 1730 |  |  |  |  |  |  |  | 400 |  | RF-22401 | SK1730 | PU02 ADDITIVE SYSTEM COMPONENTS (PK-21-/22401) |  |  | EQ | at BG-22401 +30.00 | 0,95 | a |  |  |
| RF-22402 |  | ADDITIVE UNLOADING STATION OUTLET FEEDER |  | 10d | 2012-02-02 | 2012-02-14 | BG-22402, XC40173020, P3U02S1 (other project) | -1.88d | 28.12d |  |  | Static Equipment < 10 tons [0.1 t]; Static equipment < 10t [10 h] | 400 | 10,00 |  |  |  |  |  |  |  |  | RF-22402 | 10 | 0 |  |  | 17 |  |  |  |  | X | B |  | 1730 |  |  |  |  |  |  |  | 400 |  | RF-22402 | SK1730 | PU02 ADDITIVE SYSTEM COMPONENTS (PK-21-/22401) |  |  | EQ | at BG-22402 +30.00 | 0,95 | a |  |  |
| RF-22403 |  | ADDITIVE UNLOADING STATION OUTLET FEEDER |  | 10d | 2012-02-02 | 2012-02-14 | BG-22403, P3U02S1 (other project), XC40173020 | -1.88d | 28.12d |  |  | Static Equipment < 10 tons [0.1 t]; Static equipment < 10t [9.5 h] | 380 | 9,50 |  |  |  |  |  |  |  |  | RF-22403 | 9,5 | 0 |  |  | 17 |  |  |  |  | X | B |  | 1730 |  |  |  |  |  |  |  | 400 |  | RF-22403 | SK1730 | PU02 ADDITIVE SYSTEM COMPONENTS (PK-21-/22401) |  |  | EQ | at BG-22403 +30.00 | 0,95 | a |  |  |
| RF-22404 |  | PEROXIDE UNLOADING STATION OUTLET FEEDER |  | 10d | 2012-02-02 | 2012-02-14 | BG-22404, P3U02S1 (other project), XC40173020 | -1.88d | 28.12d |  |  | Static Equipment < 10 tons [0.1 t]; Static equipment < 10t [9.5 h] | 380 | 9,50 |  |  |  |  |  |  |  |  | RF-22404 | 9,5 | 0 |  |  | 17 |  |  |  |  | X | B |  | 1730 |  |  |  |  |  |  |  | 400 |  | RF-22404 | SK1730 | PU02 ADDITIVE SYSTEM COMPONENTS (PK-21-/22401) |  |  | EQ | at BG-22404 +30.00 | 0,95 | a |  |  |
| RF-22405 |  | ADDITIVE UNLOADING STATION OUTLET FEEDER |  | 10d | 2012-02-02 | 2012-02-14 | XC40173020, BG-22405, P3U02S1 (other project) | -1.88d | 28.12d |  |  | Static Equipment < 10 tons [0.1 t]; Static equipment < 10t [9.5 h] | 380 | 9,50 |  |  |  |  |  |  |  |  | RF-22405 | 9,5 | 0 |  |  | 17 |  |  |  |  | X | B |  | 1730 |  |  |  |  |  |  |  | 400 |  | RF-22405 | SK1730 | PU02 ADDITIVE SYSTEM COMPONENTS (PK-21-/22401) |  |  | EQ | at BG-22405 +30.00 | 0,95 | a |  |  |
| RF-22407 |  | ADDITIVE UNLOADING STATION OUTLET FEEDER |  | 10d | 2012-02-02 | 2012-02-14 | XC40173020, P3U02S1 (other project), BG-22407 | -1.88d | 28.12d |  |  | Static equipment < 10t [9.5 h]; Static Equipment < 10 tons [0.1 t] | 380 | 9,50 |  |  |  |  |  |  |  |  | RF-22407 | 9,5 | 0 |  |  | 17 |  |  |  |  | X | B |  | 1730 |  |  |  |  |  |  |  | 400 |  | RF-22407 | SK1730 | PU02 ADDITIVE SYSTEM COMPONENTS (PK-21-/22401) |  |  | EQ | at BG-22407 +30.00 | 0,95 | a |  |  |
| RF-22451 |  | PP POWDER VENT ROTARY FEEDER |  | 5d | 2012-02-02 | 2012-02-08 | P3U22S1 (other project), BG-22404, XB001736 FF, XB001736 SS | 12d | 54.62d |  |  | Static Equipment < 10 tons [2.6 t]; Static equipment < 10t [260 h] | 10,400 | 260,00 |  |  |  |  |  |  |  |  | RF-22451 | 260 | 0 |  |  | 17 |  |  |  |  | X | B |  | 1736 |  |  |  |  |  |  |  | 2200 | 2 DC 8990/ 4 | RF-22451 | SK1730 | PU22 VENT COLLECTION AND VACUUM SYSTEM | Zeppelin | Zeppelin | EQ | structure +31.80 | 2,6 | a |  |  |
| F-21401 |  | ADDITIVE HOPPER SOCK FILTER |  | 10d | 2012-02-13 | 2012-02-25 | XN601730, HP-21401, XC40173020, P3U02S1 (other project), XN301730 | -10.88d | 19.12d |  |  | Static Equipment < 10 tons [0.04 t]; Static equipment < 10t [4 h] | 160 | 4,00 |  |  |  |  |  |  |  |  | F-21401 | 4 | 0 |  |  | 17 |  |  |  |  | X | B |  | 1730 |  |  |  |  |  |  |  | 400 |  | F-21401 | SK1730 | PU02 ADDITIVE SYSTEM COMPONENTS (PK-21-/22401) |  |  | EQ | at HP-21401 +26.750 | 0,04 | a |  |  |
| F-21402 |  | ADDITIVE HOPPER SOCK FILTER |  | 10d | 2012-02-13 | 2012-02-25 | HP-21402, XN301730, P3U02S1 (other project), XC40173020, XN601730 | -10.88d | 19.12d |  |  | Static Equipment < 10 tons [0.04 t]; Static equipment < 10t [4 h] | 160 | 4,00 |  |  |  |  |  |  |  |  | F-21402 | 4 | 0 |  |  | 17 |  |  |  |  | X | B |  | 1730 |  |  |  |  |  |  |  | 400 |  | F-21402 | SK1730 | PU02 ADDITIVE SYSTEM COMPONENTS (PK-21-/22401) |  |  | EQ | at HP-21402 +26.750 | 0,04 | a |  |  |
| F-21403 |  | ADDITIVE HOPPER SOCK FILTER |  | 10d | 2012-02-13 | 2012-02-25 | XC40173020, HP-21403, XN301730, XN601730, P3U02S1 (other project) | -10.88d | 19.12d |  |  | Static equipment < 10t [4 h]; Static Equipment < 10 tons [0.04 t] | 160 | 4,00 |  |  |  |  |  |  |  |  | F-21403 | 4 | 0 |  |  | 17 |  |  |  |  | X | B |  | 1730 |  |  |  |  |  |  |  | 400 |  | F-21405 | SK1730 | PU02 ADDITIVE SYSTEM COMPONENTS (PK-21-/22401) |  |  | EQ | at HP-21403 +26.750 | 0,04 | a |  |  |
| F-21404 |  | PEROXIDE UNLOADING SOCK FILTER |  | 10d | 2012-02-13 | 2012-02-25 | XC40173020, XN601730, HP-21404, P3U02S1 (other project), XN301730 | -10.88d | 19.12d |  |  | Static Equipment < 10 tons [0.04 t]; Static equipment < 10t [4 h] | 160 | 4,00 |  |  |  |  |  |  |  |  | F-21404 | 4 | 0 |  |  | 17 |  |  |  |  | X | B |  | 1730 |  |  |  |  |  |  |  | 400 |  | F-22404 | SK1730 | PU02 ADDITIVE SYSTEM COMPONENTS (PK-21-/22401) |  |  | EQ | at HP-21404 +26.750 | 0,04 | a |  |  |
| F-21405 |  | ADDITIVE HOPPER SOCK FILTER |  | 10d | 2012-02-13 | 2012-02-25 | XN601730, XC40173020, XN301730, P3U02S1 (other project), HP-21405 | -10.88d | 19.12d |  |  | Static Equipment < 10 tons [0.04 t]; Static equipment < 10t [4 h] | 160 | 4,00 |  |  |  |  |  |  |  |  | F-21405 | 4 | 0 |  |  | 17 |  |  |  |  | X | B |  | 1730 |  |  |  |  |  |  |  | 400 |  | F-21405 | SK1730 | PU02 ADDITIVE SYSTEM COMPONENTS (PK-21-/22401) |  |  | EQ | at HP-21405 +26.750 | 0,04 | a |  |  |
| F-21407 |  | ADDITIVE HOPPER SOCK FILTER |  | 10d | 2012-02-13 | 2012-02-25 | XC40173020, XN301730, XN601730, P3U02S1 (other project), HP-21407 | -10.88d | 19.12d |  |  | Static Equipment < 10 tons [0.04 t]; Static equipment < 10t [4 h] | 160 | 4,00 |  |  |  |  |  |  |  |  | F-21407 | 4 | 0 |  |  | 17 |  |  |  |  | X | B |  | 1730 |  |  |  |  |  |  |  | 400 |  | F-21407 | SK1730 | PU02 ADDITIVE SYSTEM COMPONENTS (PK-21-/22401) |  |  | EQ | at HP-21407 +26.750 | 0,04 | a |  |  |
| F-21408 |  | TALC HOPPER SOCK FILTER |  | 10d | 2012-02-13 | 2012-02-25 | HP-21408, XN301730, XC40173020, P3U02S1 (other project), XN601730 | -10.88d | 19.12d |  |  | Static equipment < 10t [4 h]; Static Equipment < 10 tons [0.04 t] | 160 | 4,00 |  |  |  |  |  |  |  |  | F-21408 | 4 | 0 |  |  | 17 |  |  |  |  | X | B |  | 1730 |  |  |  |  |  |  |  | 400 |  | F-21407 | SK1730 | PU02 ADDITIVE SYSTEM COMPONENTS (PK-21-/22401) |  |  | EQ | at HP-21408 +26.750 | 0,04 | a |  |  |
| F-22402 |  | ADDITIVE HOPPER SOCK FILTER |  | 10d | 2012-02-13 | 2012-02-25 | HP-22402, P3U02S1 (other project), XN301730, XC40173020, XN601730 | -10.88d | 19.12d |  |  | Static Equipment < 10 tons [0.04 t]; Static equipment < 10t [4 h] | 160 | 4,00 |  |  |  |  |  |  |  |  | F-22402 | 4 | 0 |  |  | 17 |  |  |  |  | X | B |  | 1730 |  |  |  |  |  |  |  | 400 |  | F-21402 | SK1730 | PU02 ADDITIVE SYSTEM COMPONENTS (PK-21-/22401) |  |  | EQ | at HP-22402 +26.750 | 0,04 | a |  |  |
| F-22403 |  | ADDITIVE HOPPER SOCK FILTER |  | 10d | 2012-02-13 | 2012-02-25 | P3U02S1 (other project), XN301730, XN601730, HP-22403, XC40173020 | -10.88d | 19.12d |  |  | Static Equipment < 10 tons [0.04 t]; Static equipment < 10t [4 h] | 160 | 4,00 |  |  |  |  |  |  |  |  | F-22403 | 4 | 0 |  |  | 17 |  |  |  |  | X | B |  | 1730 |  |  |  |  |  |  |  | 400 |  | F-22403 | SK1730 | PU02 ADDITIVE SYSTEM COMPONENTS (PK-21-/22401) |  |  | EQ | at HP-22403 +26.750 | 0,04 | a |  |  |
| F-22404 |  | PEROXIDE UNLOADING SOCK FILTER |  | 10d | 2012-02-13 | 2012-02-25 | XN301730, P3U02S1 (other project), HP-22404, XN601730, XC40173020 | -10.88d | 19.12d |  |  | Static Equipment < 10 tons [0.04 t]; Static equipment < 10t [4 h] | 160 | 4,00 |  |  |  |  |  |  |  |  | F-22404 | 4 | 0 |  |  | 17 |  |  |  |  | X | B |  | 1730 |  |  |  |  |  |  |  | 400 |  | F-22404 | SK1730 | PU02 ADDITIVE SYSTEM COMPONENTS (PK-21-/22401) |  |  | EQ | at HP-22404 +26.750 | 0,04 | a |  |  |
| F-22405 |  | ADDITIVE HOPPER SOCK FILTER |  | 10d | 2012-02-13 | 2012-02-25 | XN301730, P3U02S1 (other project), HP-22405, XN601730, XC40173020 | -10.88d | 19.12d |  |  | Static Equipment < 10 tons [0.04 t]; Static equipment < 10t [4 h] | 160 | 4,00 |  |  |  |  |  |  |  |  | F-22405 | 4 | 0 |  |  | 17 |  |  |  |  | X | B |  | 1730 |  |  |  |  |  |  |  | 400 |  | F-22405 | SK1730 | PU02 ADDITIVE SYSTEM COMPONENTS (PK-21-/22401) |  |  | EQ | at HP-22405 +26.750 | 0,04 | a |  |  |
| F-22407 |  | ADDITIVE HOPPER SOCK FILTER |  | 10d | 2012-02-13 | 2012-02-25 | XC40173020, XN601730, XN301730, P3U02S1 (other project), HP-22407 | -10.88d | 19.12d |  |  | Static Equipment < 10 tons [0.04 t]; Static equipment < 10t [4 h] | 160 | 4,00 |  |  |  |  |  |  |  |  | F-22407 | 4 | 0 |  |  | 17 |  |  |  |  | X | B |  | 1730 |  |  |  |  |  |  |  | 400 |  | F-22407 | SK1730 | PU02 ADDITIVE SYSTEM COMPONENTS (PK-21-/22401) |  |  | EQ | at HP-22407 +26.750 | 0,04 | a |  |  |
| RF-21434 |  | BAG UNLOADING OUTLET ROTARY VALVE |  | 12.5d | 2012-03-20 | 2012-04-03 | XB001736 SS, XX-21401, XB001736 FF, BG-21435 SS, P3U10S1A (other project), XC40173620 | -42.62d | 0d |  |  | Static Equipment < 10 tons [0.38 t]; Static equipment < 10t [38 h] | 1,520 | 38,00 |  |  |  |  |  |  |  |  | RF-21434 | 38 | 0 |  |  | 17 |  |  |  |  | X | B |  | 1736 |  |  |  |  |  |  |  | 2200 | 2 DC 8990/ 4 | RF-21434 | SK1730 | PU10 CONVEYING SYSTEM (PK-21501) ZEPPELIN | Zeppelin | Zeppelin | EQ | structure +31.2 | 0,38 | a |  |  |
| RF-21435 |  | OUTLET ROTARY VALVE |  | 12.5d | 2012-03-20 | 2012-04-03 | P3U10S1A (other project), RF-21434 SS, XB001736 SS, XC40173620, XB001736 FF | -42.62d | 0d |  |  | Static Equipment < 10 tons [0.38 t]; Static equipment < 10t [38 h] | 1,520 | 38,00 |  |  |  |  |  |  |  |  | RF-21435 | 38 | 0 |  |  | 17 |  |  |  |  | X | B |  | 1736 |  |  |  |  |  |  |  | 2200 | 2 DC 8990/ 4 | RF-21435 | SK1730 | PU10 CONVEYING SYSTEM (PK-21501) ZEPPELIN | Zeppelin | Zeppelin | EQ | concrete +31.80 | 0,38 | a |  |  |

Notes:
- XH00173005: Current Status: 110310 (WL) Delete XC501730 CA17 ExtrBldgFl4 - Finishing Works / Rooms

| ID | WBS | Activity | Duration | Start | Finish | Predecessors | Total float | Free float | Constraint | Calendar | Resources | Cost | TB26 Ressource Budget | UDF_Weight (ton) | POSITION | WEIGHT | UDF_LEVEL | UDF_PO No | UDF_TAG No | UDF_Object No | UDF_DELIVERY DATE PO | UDF_DELIVERY DATE DISPATCH PLANNED | UDF_DELIVERY DATE TO SITE PLANNED | UDF_DELIVERY DATE SITE NEED DATE | UDF_PACKAGE | UDF_SUPPLIER | UDF_Vendor Representatives | UDF_SAVE ACT ID | UDF_BUDGETED LABOR UNIT | UDF_ACTUAL LABOR UNIT | Constr. Area | Zeigen/n. Zeigen | WBS Phase | WBS Discipline | WBS Objects | UDF_SELECT | UDF_SELECT UPDATE PROGRESS | UDF_COMMENTS_0827 | Department | Type of Work | Inquiry/Order No | PMT-Area | PMT-Schedule Org | PMT-Phase | PMT-Respons. | WBS Type of Work | Russia WBS Discipline (Russia) | Russia Construction Area | Russia WBS Phase | IMS | UPT | Russia WBS Objects | UDF_CONTRACT START DATE | UDF_CONTRACT FINISH DATE | UDF_CONTRACT ITEM | UDF_PLANNED START | UDF_PLANNED FINISH | Subcontractor | UDF_CONTRACT FINISH DATE REV1 | UDF_CONTRACT START DATE REV1 | UDF_CONTRACT DATE PENALIZED | UDF_INDICATOR | TB26 Semantics | TB26 Material Res Values | UDF_ELECTRICAL START | UDF_ELECTRICAL FINISH | UDF_CHECK BASELINE | UDF_PENALIZED FINISH |
| --- | --- | --- | --- | --- | --- | --- | --- | --- | --- | --- | --- | --- | --- | --- | --- | --- | --- | --- | --- | --- | --- | --- | --- | --- | --- | --- | --- | --- | --- | --- | --- | --- | --- | --- | --- | --- | --- | --- | --- | --- | --- | --- | --- | --- | --- | --- | --- | --- | --- | --- | --- | --- | --- | --- | --- | --- | --- | --- | --- | --- | --- | --- | --- | --- | --- | --- | --- | --- |
|  | M | **Mechanical - Rotating Equipment** |  | 2011-11-18 | 2011-12-12 |  |  |  |  |  |  |  |  |  |  |  |  |  |  |  |  |  |  |  |  |  |  |  |  |  |  |  |  |  |  |  |  |  |  |  |  |  |  |  |  |  |  |  |  |  |  |  |  |  |  |  |  |  |  |  |  |  |  |  |  |  |  |  |
| RF-21304 |  | PURGE COLUMN OUTLET ROTARY FEEDER 500 | 25d | 2011-11-18 | 2011-12-12 | XN301720, XC40171820, ER291700 (other project), XC40172020, HP-21405, HP-21401, P3M12S1 (other project) | 61d | 69d |  | TB26 - 3 - Construction Normal 7days * CA17 | Rotating Equipment (w/o lube oil unit) [11.84 t]; Rotating equipment (w/o lube oil unit) [1184.3 h] | 41,440 | 1184,30 | 1,9 | a | 1900 | concrete +19.700 (roof) | 2 DC 8940/ 4 | RF-21304 | SK1730 | 2010-10-20 | 2011-01-15 | 2011-01-30 | 2011-04-10 | M12 ROTARY FEEDER (RF-21-/22301/4) | Zeppelin | 030 | RF-21304 | 1184,3 | 0 | 17 | EQ | X | M | 1730 |  |  |  |  |  |  |  |  |  |  |  |  |  |  |  |  |  |  |  |  |  |  |  |  |  |  |  |  |  |  |  |  |  |
| RF-22304 |  | PURGE COLUMT OUTLET ROTARY FEED 500 | 25d | 2011-11-18 | 2011-12-12 | XC40171820, P3M12S1 (other project), HP-22401, HP-22405, XC40172020, XN301720, ER291700 (other project) | 61d | 69d |  | TB26 - 3 - Construction Normal 7days * CA17 | Rotating Equipment (w/o lube oil unit) [11.84 t]; Rotating equipment (w/o lube oil unit) [1184.3 h] | 41,450.5 | 1184,30 | 1,9 | a | 1900 | concrete +19.700 (roof) | 2 DC 8940/ 4 | RF-22304 | SK1730 | 2010-10-20 | 2011-01-15 | 2011-01-30 | 2011-04-10 | M12 ROTARY FEEDER (RF-21-/22301/4) | Zeppelin | 030 | RF-22304 | 1184,3 | 0 | 17 | EQ | X | M | 1730 |  |  |  |  |  |  |  |  |  |  |  |  |  |  |  |  |  |  |  |  |  |  |  |  |  |  |  |  |  |  |  |  |  |
|  | R | **Piping** |  | 2011-09-15 | 2012-05-24 |  |  |  |  |  |  |  |  |  |  |  |  |  |  |  |  |  |  |  |  |  |  |  |  |  |  |  |  |  |  |  |  |  |  |  |  |  |  |  |  |  |  |  |  |  |  |  |  |  |  |  |  |  |  |  |  |  |  |  |  |  |  |  |
| XR201730 |  | CA17 ExtrBldgFl4 - Piping Prefabrication | 110d | 2011-09-15 | 2012-01-10 | ER491730 (other project) SS+12d, ER49173005 (other project) SS+12d, XR500C00 FS+15d | 16d | 0d | start on or after 2011-09-15 | TB26 - 3 - Construction Normal 7days * CA17 | A/G piping prefabrication [1250 Fpi]; Conveying S. piping prefabrication [100 Fpi]; A/G Piping (Prefab) [4687.5 h]; Conveying system (Prefab) [250 h] | 20,602.22 | 4937,50 |  |  |  |  |  |  |  |  |  |  |  |  |  |  | XR201730 | 4937,5 | 0 | 17 |  | X | R | 1730 | OMUS-1 | 27.8. | Start mid of sept | 934 | PU10 | 2DC8990 | 200 | 200 | C | LND | XR20 | R | 17 | X | PRP | LND | 1730 |  |  |  |  |  |  |  |  |  |  |  |  |  |  |  |  |
| XR401730 |  | CA17 ExtrBldgFl4 - Piping Installation | 90d | 2012-01-12 | 2012-04-12 | F-22403 FF+20d, RF-22403 FF+20d, RF-22402 FF+20d, F-22402 FF+20d, XC701730 FF+25d, F-21408 FF+20d, XX-21401 FF+20d, XX-22401 FF+20d, F-21407 FF+20d, RF-22407 FF+20d, F-21401 FF+20d, RF-21407 FF+20d, F-22405 FF+20d, F-21405 FF+20d, RF-21403 FF+20d, F-21402 FF+20d, F-21403 FF+20d, RF-21405 FF+20d, RF-22401 FF+20d, RF-22404 FF+20d, RF-21408 FF+20d, RF-21401 FF+20d, F-21452 FF+20d, F-22401 FF+20d, F-22404 FF+20d, RF-22405 FF+20d, RF-21404 FF+20d, F-22407 FF+20d, F-21404 FF+20d, XR201730 SS+60d, XR201730 FF+10d, XN601730 FF+30d, XN801730 SS+30d, SL-21402 FF+20d, RF-21402 FF+20d, BL-21452 FF+20d, IMS-C-000190 FF | -35d | 0d |  | TB26 - 3 - Construction Normal 7days * CA17 | A/G piping field installation [2090 Fpi]; Conveying S. piping field installation [60 Fpi]; Control & Shut-off valves [26 pcs]; A/G Piping (Field) [13062.5 h]; Conveying system (Field) [300 h]; Install Control & Shut-off Valves [136.5 h] | 52,153.49 | 13499,00 |  |  |  |  |  |  |  |  |  |  |  |  |  |  | XR401730 | 13499 | 0 | 17 |  | X | R | 1730 | OMUS-1 |  |  | 934 | PU10 | 2DC8990 | 200 | 200 | C | LND | XR40 | R | 17 | X | PI | LND | 1730 | 2011-02-25 | 2012-02-25 | E-06-03-07 | 2011-05-12 |  |  |  |  |  |  |  |  |  |  |  |  |
| XR601730 |  | CA17 ExtrBldgFl4 - Piping Pressure Tests | 60d | 2012-03-14 | 2012-05-14 | XR401730 FF+30d, XR401730 SS+30d | -35d | 0d |  | TB26 - 3 - Construction Normal 7days * CA17 |  |  | 1241 |  |  |  |  |  |  |  |  |  |  |  |  |  |  | XR601730 | 0 | 0 | 17 |  | X | R | 1730 | OMUS-1 |  |  | 934 |  |  | 200 | 200 | C | LND | XR60 | R | 17 | X | HY | LND | 1730 | 2011-02-25 | 2012-02-25 | E-06-03-07 |  |  |  |  |  |  |  |  |  |  |  |  |  |
| XR801730 |  | CA17 ExtrBldgFl4 - Piping Reinstatement | 50d | 2012-04-03 | 2012-05-24 | XR601730 FF+10d, IMS-C-000190 FF, IMS-C-000360 FF | -22d | 0d |  | TB26 - 3 - Construction Normal 7days * CA17 |  |  | 620 |  |  |  |  |  |  |  |  |  |  |  |  |  |  | XR801730 | 0 | 0 | 17 |  | X | R | 1730 | OMUS-1 |  |  | 934 |  |  | 200 | 200 | C | LND | XR80 | R | 17 | X | PI | LND | 1730 | 2011-02-25 | 2012-02-25 | E-06-03-07 |  | 2012-05-11 |  |  |  |  |  |  |  |  |  |  |  |
|  | E | **Electrical** |  | 2011-12-06 | 2012-10-09 |  |  |  |  |  |  |  |  |  |  |  |  |  |  |  |  |  |  |  |  |  |  |  |  |  |  |  |  |  |  |  |  |  |  |  |  |  |  |  |  |  |  |  |  |  |  |  |  |  |  |  |  |  |  |  |  |  |  |  |  |  |  |  |
| XC911730 |  | CA17 ExtrBldgFl4 - Install Earthing&Lightn.Sys_CIVIL | 20d | 2011-12-06 | 2011-12-25 | EE901730 (other project), XC40173020 FF | 63d | 55d |  | TB26 - 3 - Construction Normal 7days * CA17 | Grounding & Lightning [240 pcs]; Grounding & Lightning [2700 h] | 108,000 | 2700,00 |  |  |  |  |  |  |  |  |  |  |  |  |  |  | XC911730 | 2700 | 0 | 17 |  | X | C | 1730 |  |  |  | 934 |  |  | 200 | 200 | C | LND | XE91 | C | 17 | X | EA | LND | 1730 | 2011-08-30 | 2012-01-30 | E-16-07-10 |  |  | MO11 |  |  |  |  |  |  |  |  |  |  |
| XE911731 |  | CA17 ExtrBldgFl4 - Install Earthing&Lightn.Sys_E/I | 26d | 2012-02-14 | 2012-03-13 | XN301730, RF-21402 | 106.12d | 217.62d |  | TB26 - 3 - Construction Normal 7days * CA17 |  |  | 265 |  |  |  |  |  |  |  |  |  |  |  |  |  |  | XE911731 | 0 | 0 | 17 |  | X | E | 1730 |  |  |  | 934 |  |  | 200 | 200 | C | LND | XE91 | E | 17 | X | EA | LND | 1730 | 2011-08-30 | 2012-01-30 | E-16-07-10 |  |  | URMA | 2012-07-20 | 2011-12-01 |  |  |  |  |  |  |  |  |
| XE341730 |  | CA17 ExtrBldgFl4 - Install Local Operation Panels | 50d | 2012-03-03 | 2012-04-22 | EE46173010 (other project), XE401730 FF, XR401730 FS-40d, RF-21402 | 338.5d |  |  | TB26 - 3 - Construction Normal 7days * CA17 | Field Panels [11 pcs]; Field panels [220 h] | 8,800 | 220,00 |  |  |  |  |  |  |  |  |  |  |  |  |  |  | XE341730 | 220 | 0 | 17 |  | X | E | 1730 |  |  | after equipm. erection & 50% piping | 934 |  |  | 200 | 200 | C | LND | XE34 | E | 17 | X | EL | LND | 1730 | 2011-08-30 | 2012-01-30 | E-16-07-10 |  |  | URMA | 2012-07-20 | 2011-12-01 | x | UDF_G2 |  |  |  |  |  |  |
| XE401730 |  | CA17 ExtrBldgFl4 - Install Cable Trays | 50d | 2012-03-03 | 2012-04-22 | XN801730, XR401730 FS-40d, EE46173010 (other project), XN601730 FF+30d | -2d | 0d |  | TB26 - 3 - Construction Normal 7days * CA17 | Cable trays/conduits [600 m]; Cable trays [1800 h] | 72,000 | 1800,00 |  |  |  |  |  |  |  |  |  |  |  |  |  |  | XE401730 | 1800 | 0 | 17 |  | X | E | 1730 |  |  | after equipm. erection & 50% piping | 934 |  |  | 200 | 200 | C | LND | XE40 | E | 17 | X | EL | LND | 1730 | 2011-06-10 | 2011-11-30 | E-15-01-11 |  |  | URMA | 2012-04-01 | 2011-09-20 |  | UDF_G2 | m | 1500 | 2011-10-13 | 2012-01-08 | x |  |
| XE701730 |  | CA17 ExtrBldgFl4 - Install Lighting &Small Power | 50d | 2012-04-03 | 2012-05-24 | XH00173005 SS+20d, EE76510110 (other project) FF+20d, XE401730 FS-20d, P3E09S (other project), EE761700 (other project), XP341610 FS+50d, P3E03S2 (other project) FF+20d, EE76170010 (other project) FF+20d, XC501730 FS-30d | 36d | 147.5d |  | TB26 - 3 - Construction Normal 7days * CA17 | Lighting illuminates [150 pcs]; Lighting (iluminates) [1500 h] | 60,000 | 1500,00 |  |  |  |  |  |  |  |  |  |  |  |  |  |  | XE701730 | 1500 | 0 | 17 |  | X | E | 1730 |  |  |  | 934 |  |  | 200 | 200 | C | LND | XE70 | E | 16 | X | EL | LND | 1610 | 2011-05-10 | 2012-01-31 | E-16-03-01 |  |  | URMA | 2012-05-10 | 2011-08-15 |  | UDF_G3 |  |  |  |  |  |  |
| XE801730 |  | CA17 ExtrBldgFl4 - Install Heat Tracing | 40d | 2012-04-13 | 2012-05-24 | IMS-C-000280 FF, E3E1950 (other project), XR401730 FS-40d, XR601730 FS-30d | -35d | 0d |  | TB26 - 3 - Construction Normal 7days * CA17 | Electrical Heat Tracing [900 m]; Electrical heat tracing [450 h] | 18,000 | 450,00 |  |  |  |  |  |  |  |  |  |  |  |  |  | 005 | XE801730 | 450 | 0 | 17 |  | X | E | 1730 |  |  |  | 934 |  |  | 200 | 200 | C | LND | XE80 | E | 17 | X | HT | LND | 1730 | 2011-06-20 | 2012-03-20 | E-16-04-01 |  |  | URMA | 2012-06-30 | 2011-09-15 |  | UDF_G3 |  |  |  |  |  |  |
| XE50173010 |  | CA17 ExtrBldgFl4 - Cable Pulling Electric Part II (over SR1708) | 30d | 2012-07-06 | 2012-08-10 | XE401730 FS-20d, XE500C01, XE501708 FS-20d, EE561730 (other project) | -67.5d | 10d |  | TB26 - V - Construct-Winter partly * | Cable Pulling [7000 m]; Cable pulling [3500 h] | 140,000 | 3500,00 |  |  |  |  |  |  |  |  |  |  |  |  |  |  | XE50173010 | 3500 | 0 | 17 |  | X | E | 1730 |  |  |  | 934 |  |  | 200 | 200 | C | LND | XE50 | E | 17 | X | EL | LND | 1730 | 2011-05-20 | 2012-02-10 | E-16-01-01 |  |  | URMA | 2012-07-01 | 2011-10-01 |  | UDF_G3 | m | 7250 | 2012-02-15 | 2012-03-17 |  |  |
| XE50173005 |  | CA17 ExtrBldgFl4 - Cable Pulling Electric Part I (over SR1707) | 30d | 2012-07-18 | 2012-08-22 | XE401730 FS-20d, XE500C01, EE561730 (other project), XE501707 FS-20d | -77.5d | 0d |  | TB26 - V - Construct-Winter partly * | Cable Pulling [7000 m]; Cable pulling [3500 h] | 140,000 | 3500,00 |  |  |  |  |  |  |  |  |  |  |  |  |  |  | XE50173005 | 3500 | 0 | 17 |  | X | E | 1730 |  |  |  | 934 |  |  | 200 | 200 | C | LND | XE50 | E | 17 | X | EL | LND | 1730 | 2011-05-20 | 2012-02-10 | E-16-01-01 |  |  | URMA | 2012-07-01 | 2011-10-01 |  | UDF_G3 | m | 7250 | 2011-12-23 | 2012-01-28 |  |  |
| XE601730 |  | CA17 ExtrBldgFl4 - Cable Termination & Testing | 60d | 2012-08-10 | 2012-10-09 | XE50173010 FS-10d, XE50173005 FS-10d, RF-21402 | -90.5d | 0d |  | TB26 - 3 - Construction Normal 7days * CA17 | Cable connecting [210 pcs]; Cable connecting [525 h] | 21,000 | 525,00 |  |  |  |  |  |  |  |  |  |  |  |  |  |  | XE601730 | 525 | 0 | 17 |  | X | E | 1730 |  |  |  | 934 |  |  | 200 | 200 | C | LND | XE60 | E | 17 | X | ET | LND | 1730 | 2011-04-20 | 2011-11-30 | E-16-02-01 |  |  | URMA | 2012-08-14 | 2011-12-10 |  | UDF_G2 |  |  |  |  |  |  |
|  | J | **Instrumentation** |  | 2012-02-27 | 2012-11-19 |  |  |  |  |  |  |  |  |  |  |  |  |  |  |  |  |  |  |  |  |  |  |  |  |  |  |  |  |  |  |  |  |  |  |  |  |  |  |  |  |  |  |  |  |  |  |  |  |  |  |  |  |  |  |  |  |  |  |  |  |  |  |  |
| XJ321730 |  | CA17 ExtrBldgFl4 - Install Junction Boxes | 40d | 2012-02-27 | 2012-04-07 | XR401730 FS-45d, XC911730, EJ321730 (other project) | 8d | 0d |  | TB26 - 3 - Construction Normal 7days * CA17 | Junction Boxes/Cabinets/Panels [25 pcs]; Install Junction Boxes/ Cabinets/ Panels [625 h] | 25,000 | 625,00 |  |  |  |  |  |  |  |  |  |  |  |  |  |  | XJ321730 | 625 | 0 | 17 |  | X | J | 1730 |  |  | Civil 100%, Equipment 100%, Piping 50% | 934 |  |  | 200 | 200 | C | LND | XJ32 | J | 17 | X | IN | LND | 1730 | 2011-08-30 | 2012-03-30 | E-17-04-10 |  |  | URMA | 2012-07-30 | 2012-01-01 |  | UDF_G2 |  |  |  |  |  |  |
| XJ441730 |  | CA17 ExtrBldgFl4 - Install Conduits to Instrm | 50d | 2012-03-27 | 2012-05-17 | XJ321730 FS-12d | 13d | 27d |  | TB26 - 3 - Construction Normal 7days * CA17 |  |  |  |  |  |  |  |  |  |  |  |  |  |  |  |  |  | XJ441730 | 0 | 0 | 17 |  | X | J | 1730 |  |  |  | 934 |  |  | 200 | 200 | C | LND | XJ44 | J | 17 | X | IN | LND | 1730 | 2011-08-30 | 2012-03-30 | E-17-04-10 |  |  | URMA | 2012-07-30 | 2012-01-01 |  | UDF_G2 |  |  |  |  |  |  |
| XJ421730 |  | CA17 ExtrBldgFl4 - Install Secondary Cable Trays | 60d | 2012-03-29 | 2012-05-29 | XJ321730 FS-20d, XE401730 FS-25d, EJ46173010 (other project), XR401730 FS-45d | -2d | 15d |  | TB26 - 3 - Construction Normal 7days * CA17 | Secondary cable trays [430 m]; Install secondary cable trays [1612.5 h] | 64,500 | 1612,50 |  |  |  |  |  |  |  |  |  |  |  |  |  |  | XJ421730 | 1612,5 | 0 | 17 |  | X | J | 1730 |  |  |  | 934 |  |  | 200 | 200 | C | LND | XJ42 | J | 17 | X | IN | LND | 1730 | 2011-08-30 | 2011-11-30 | E-15-01-11 |  |  | URMA | 2012-04-01 | 2011-09-20 |  | UDF_G2 | m | 673 | 2011-10-13 | 2012-01-08 | x |  |
| XJ301730 |  | CA17 ExtrBldgFl4 - Install Field Instruments | 50d | 2012-04-28 | 2012-06-19 | XR801730 FS-25d, EJ361730 (other project), XR401730 FS-45d | -22d | 0d |  | TB26 - 3 - Construction Normal 7days * CA17 | Field Instruments [40 pcs]; Install field instruments [220 h] | 8,800 | 220,00 |  |  |  |  |  |  |  |  |  |  |  |  |  |  | XJ301730 | 220 | 0 | 17 |  | X | J | 1730 |  |  |  | 934 |  |  | 200 | 200 | C | LND | XJ30 | J | 17 | X | IN | LND | 1730 | 2011-08-30 | 2012-03-30 | E-17-04-10 |  |  | URMA | 2012-07-30 | 2012-01-01 | x | UDF_G2 |  |  |  |  |  |  |
| XJ391730 |  | CA17 ExtrBldgFl4 - Install Earthing Field Eqpt | 40d | 2012-05-25 | 2012-07-04 | XJ301730 FS-25d, XJ421730 FS-20d, XJ441730 FS-20d | -14d | 8d |  | TB26 - 3 - Construction Normal 7days * CA17 |  |  |  |  |  |  |  |  |  |  |  |  |  |  |  |  |  | XJ391730 | 0 | 0 | 17 |  | X | J | 1730 |  |  |  | 934 |  |  | 200 | 200 | C | LND | XJ39 | J | 17 | X | IN | LND | 1730 | 2011-08-30 | 2012-03-30 | E-17-04-10 |  |  | URMA | 2012-07-30 | 2012-01-01 |  | UDF_G2 |  |  |  |  |  |  |
| XJ701730 |  | CA17 ExtrBldgFl4 - Instrument Tubing | 40d | 2012-05-25 | 2012-07-04 | XJ301730 FS-25d | -14d | 8d |  | TB26 - 3 - Construction Normal 7days * CA17 |  |  |  |  |  |  |  |  |  |  |  |  |  |  |  |  |  | XJ701730 | 0 | 0 | 17 |  | X | J | 1730 |  |  |  | 934 |  |  | 200 | 200 | C | LND | XJ70 | J | 17 | X | IN | LND | 1730 | 2011-08-30 | 2012-03-30 | E-17-04-10 |  |  | URMA | 2012-07-30 | 2012-01-01 |  | UDF_G3 |  |  |  |  |  |  |
| XJ541730 |  | CA17 ExtrBldgFl4 - Pulling Singlecore Cables | 40d | 2012-06-20 | 2012-08-04 | XJ421730, EJ801730 (other project), XE500C01, XJ441730 FS-20d, XJ301730 | -19d | 0d |  | TB26 - V - Construct-Winter partly * | Singlecore cables [3600 m]; Pull singlecore cables [2700 h] | 108,000 | 2700,00 |  |  |  |  |  |  |  |  |  |  |  |  |  |  | XJ541730 | 2700 | 0 | 17 |  | X | J | 1730 |  |  |  | 934 |  |  | 200 | 200 | C | LND | XJ54 | J | 17 | X | IN | LND | 1730 | 2011-08-30 | 2012-03-30 | E-17-04-10 |  |  | URMA | 2012-07-30 | 2012-01-01 |  | UDF_G3 | m | 3430 | 2012-03-06 | 2012-04-15 |  |  |
| XJ641730 |  | CA17 ExtrBldgFl4 - Termin Singlecore Cables | 40d | 2012-07-13 | 2012-08-21 | XJ541730 FS-20d, XJ301730 FS-20d, XJ321730, XJ391730, XJ701730 | -22d | 68.5d |  | TB26 - 3 - Construction Normal 7days * CA17 | Termination Field [1413 mhr]; Termination field [1413 h] | 141,300 | 1413,00 |  |  |  |  |  |  |  |  |  |  |  |  |  |  | XJ641730 | 1413 | 0 | 17 |  | X | J | 1730 |  |  |  | 934 |  |  | 200 | 200 | C | LND | XJ64 | J | 17 | X | IN | LND | 1730 | 2011-08-30 | 2012-03-30 | E-17-04-10 |  |  | URMA | 2012-07-30 | 2012-01-01 |  | UDF_G3 |  |  |  |  |  |  |
| XJ521730 |  | CA17 ExtrBldgFl4 - Pulling Multicore Cables | 40d | 2012-07-16 | 2012-08-31 | XJ521707 FS-10d, XE500C01, XJ321730 FS-20d, XJ521708 FS-10d, XE401730 | -41.5d | 0d |  | TB26 - V - Construct-Winter partly * | Multicore cables [4000 m]; Pull multicore cables [2000 h] | 80,000 | 2000,00 |  |  |  |  |  |  |  |  |  |  |  |  |  |  | XJ521730 | 2000 | 0 | 17 |  | X | J | 1730 |  |  |  | 934 |  |  | 200 | 200 | C | LND | XJ52 | J | 17 | X | IN | LND | 1730 | 2011-05-20 | 2012-03-10 | E-17-01-01 |  |  | URMA | 2012-06-16 | 2011-11-01 |  | UDF_G2 | m | 2900 | 2012-02-09 | 2012-03-21 |  |  |
| XJ621730 |  | CA17 ExtrBldgFl4 - Termin Multicore Cables | 40d | 2012-08-08 | 2012-09-17 | XJ521730 FS-20d, XH00173005, XJ321730 | -48.5d | 42d |  | TB26 - 3 - Construction Normal 7days * CA17 | Termination Field [1413 mhr]; Termination field [1413 h] | 141,300 | 1413,00 |  |  |  |  |  |  |  |  |  |  |  |  |  |  | XJ621730 | 1413 | 0 | 17 |  | X | J | 1730 |  |  |  | 934 |  |  | 200 | 200 | C | LND | XJ62 | J | 17 | X | IN | LND | 1730 | 2011-05-20 | 2012-03-10 | E-17-01-01 |  |  | URMA | 2012-06-16 | 2011-11-01 |  | UDF_G2 |  |  |  |  |  |  |
| XJ801730 |  | CA17 ExtrBldgFl4 - Inspections/ Mech. Acceptance/ Loop Checks | 40d | 2012-10-09 | 2012-11-19 | XJ701730 FS-20d, XJ391730 FS-20d, X3J120 FF, XJ641730 FS-20d, XJ621730 FS-20d, EJ801730 (other project), XE601730 | -90.5d | 26d |  | TB26 - 3 - Construction Normal 7days * CA17 | Loop Checks [220 pcs]; Loop checks [1100 h] | 44,000 | 1100,00 |  |  |  |  |  |  |  |  |  |  |  |  |  |  | XJ801730 | 1100 | 0 | 17 |  | X | J | 1730 |  |  |  | 934 |  |  | 200 | 200 | C | LND | XJ80 | J | 17 | X | LT | LND | 1730 | 2011-06-10 | 2012-04-30 | E-17-02-01 |  |  | URMA | 2012-08-18 | 2012-03-01 |  |  |  |  |  |  |  | 2012-08-18 |

Notes:
- XE911731: UDF_PREDECESSOR: XN30, DEL XE40, DEL XE80, DEL XJ40, Civil 100%, Equipment 100%
- XE341730: UDF_PREDECESSOR: XE40, Equipment 100%, Piping 50%
- XE401730: UDF_PREDECESSOR: XN30, Piping 50%
- XE701730: UDF_PREDECESSOR: XE40, Civil 100%, HVAC ducts, Finishing works partly
- XE801730: UDF_PREDECESSOR: XR40, Piping 50% pressure tests
- XE50173010: UDF_PREDECESSOR: XE40, XE50, DEL XE34
- XE50173005: UDF_PREDECESSOR: XE40, XE50, DEL XE34
- XE601730: UDF_PREDECESSOR: XE50, Equipment 100%
- XJ321730: UDF_PREDECESSOR: Civil 100%, Equipment 100%, Piping 50%
- XJ441730: UDF_PREDECESSOR: XE40, XJ32, XJ40, Equipment 100%, Piping 50%
- XJ421730: UDF_PREDECESSOR: XE40, XJ32, Equipment 100%, Piping 50%
- XJ301730: UDF_PREDECESSOR: XR80, XR40, Equipment 100%, Piping 50%
- XJ391730: UDF_PREDECESSOR: XJ30, XJ42, XJ44, DEL XJ32, DEL XR40
- XJ701730: UDF_PREDECESSOR: XJ30
- XJ541730: UDF_PREDECESSOR: XJ30, XJ42, XJ44
- XJ641730: UDF_PREDECESSOR: XJ30, XJ32, XJ39, XJ54, XJ70
- XJ521730: UDF_PREDECESSOR: XE40, XJ32, XJ52
- XJ621730: UDF_PREDECESSOR: XJ32, XJ52
- XJ801730: UDF_PREDECESSOR: XE60, XJ39, XJ62, XJ64, XJ70

| ID | WBS | Activity | Type | Duration | Start | Finish | Predecessors | Complete | Total float | Free float | Constraint | Calendar | Resources | Cost | TB26 Ressource Budget | UDF_SELECT | UDF_SELECT UPDATE PROGRESS | UDF_SAVE ACT ID | UDF_BUDGETED LABOR UNIT | UDF_ACTUAL LABOR UNIT | Department | Constr. Area | PMT-Area | PMT-Schedule Org | PMT-Phase | PMT-Respons. | WBS Phase | WBS Discipline | WBS Type of Work | WBS Objects | Russia WBS Discipline (Russia) | Russia Construction Area | Russia WBS Phase | IMS | UPT | Russia WBS Objects | UDF_CONTRACT FINISH DATE | UDF_CONTRACT ITEM | UDF_CONTRACT INDICATOR | UDF_EXPECTED START | UDF_EXPECTED FINISH | UDF_CHECK BASELINE | Subcontractor | Comments | UDF_Text4 | Zeigen/n. Zeigen | UDF_Concrete | UDF_CHECK CRITICAL PATH | Type of Work | TB26 Semantics | Inquiry/Order No |
| --- | --- | --- | --- | --- | --- | --- | --- | --- | --- | --- | --- | --- | --- | --- | --- | --- | --- | --- | --- | --- | --- | --- | --- | --- | --- | --- | --- | --- | --- | --- | --- | --- | --- | --- | --- | --- | --- | --- | --- | --- | --- | --- | --- | --- | --- | --- | --- | --- | --- | --- | --- |
|  | W | **Painting** |  |  | 2011-09-15 | 2011-11-12 |  |  |  |  |  |  |  |  |  |  |  |  |  |  |  |  |  |  |  |  |  |  |  |  |  |  |  |  |  |  |  |  |  |  |  |  |  |  |  |  |  |  |  |  |  |
| XW501730 |  | CA17 ExtrBldgFl4 - Surf.Protection Piping |  | 50d | 2011-09-15 | 2011-11-12 | XR201730 SS |  | 418.5d |  | start on or after 2011-09-15 |  | Piping painting [1056 sqm]; Piping painting [2640 h] | 1,921.63 | 2640,00 | OMUS-1 | 27.8. | XW501730 | 2640 | 0 | 934 | 17 | 200 | 200 | C | LND | X | W | XW50 | 1730 | W | 17 | X | PA | LND | 1730 |  |  |  |  |  |  |  |  |  |  |  |  |  |  |  |
|  | V | **Insulation** |  |  | 2012-05-04 | 2012-08-19 |  |  |  |  |  |  |  |  |  |  |  |  |  |  |  |  |  |  |  |  |  |  |  |  |  |  |  |  |  |  |  |  |  |  |  |  |  |  |  |  |  |  |  |  |  |
| XV301730 |  | CA17 ExtrBldgFl4 - Insulation Equipment |  | 100d | 2012-05-04 | 2012-08-13 | XE801730 SS+20d, F-21452 |  | -35d | 0d |  | TB26 - 3 - Construction Normal 7days * CA17 | Equipment insulation [350 sqm]; Equipment insulation [4375 h] | 1,370.27 | 4375,00 | OMUS-1 |  | XV301730 | 4375 | 0 | 934 | 17 | 200 | 200 | C | LND | X | V | XV30 | 1730 | V | 17 | X | INS | LND | 1730 | 2012-03-30 | E-13-03 |  |  |  |  |  |  |  |  |  |  |  |  |  |
| XV501730 |  | CA17 ExtrBldgFl4 - Insulation Piping |  | 100d | 2012-05-11 | 2012-08-19 | XR601730 SS+10d, XE801730 FF+20d, XV301730 FF+6d |  | -35d | 81.5d |  | TB26 - 3 - Construction Normal 7days * CA17 | Piping insulation [900 sqm]; Piping insulation [6750 h] | 5,475.16 | 6750,00 | OMUS-1 |  | XV501730 | 6750 | 0 | 934 | 17 | 200 | 200 | C | LND | X | V | XV50 | 1730 | V | 17 | X | INS | LND | 1730 | 2012-04-30 | E-13-01 |  |  |  |  |  |  |  |  |  |  |  |  |  |
|  | 36 | **CA17 - Extrusion Bldg 5th Floor +31,65m** |  |  | 2011-05-05 | 2012-10-19 |  |  |  |  |  |  |  |  |  |  |  |  |  |  |  |  |  |  |  |  |  |  |  |  |  |  |  |  |  |  |  |  |  |  |  |  |  |  |  |  |  |  |  |  |  |
|  | C | **Civil Work** |  |  | 2011-09-11 | 2012-04-07 |  |  |  |  |  |  |  |  |  |  |  |  |  |  |  |  |  |  |  |  |  |  |  |  |  |  |  |  |  |  |  |  |  |  |  |  |  |  |  |  |  |  |  |  |  |
| XC40173630 |  | CA17 ExtrBldgFl5 - Concrete Works Stairtowers North <36m (D-E/1-2) |  | 19d | 2011-09-11 | 2011-09-29 | XC40173030 |  | -95d | 0d |  | TB26 - 3 - Construction Normal 7days * CA17 | Concrete works [105 cbm]; Concrete works [3150 h] | 21,596.15 | 12300,00 |  |  | XC40173610 | 3150 | 0 | 934 | 17 | 200 | 200 | C | MO04 | X | C | XC40 | 1736 | C | 17 | X | EB | LND | 1736 |  |  | UDF_G4 | 2011-09-03 | 2011-09-28 | x | MO11 |  |  |  |  |  |  |  |  |
| XC40173640 |  | CA17 ExtrBldgFl5 - Concrete Works Stairtowers South <36m (D-E/4-5) |  | 20d | 2011-09-11 | 2011-09-30 | XC40173040 |  | 477.5d | 0d |  | TB26 - 3 - Construction Normal 7days * CA17 | Concrete works [138 cbm]; Concrete works [4140 h] | 21,596.15 | 12300,00 |  |  | XC40173610 | 4140 | 0 | 934 | 17 | 200 | 200 | C | MO04 | X | C | XC40 | 1736 | C | 17 | X | EB | LND | 1736 |  |  | UDF_G4 | 2011-09-11 | 2011-10-07 | x | MO11 |  |  |  |  |  |  |  |  |
| XC40173605 |  | CA17 ExtrBldgFl5 - Precast Concrete Elements Stairtowers <36m North/South |  | 30d | 2011-11-26 | 2011-12-25 | IMS-C-000020 FF, EC48173610 (other project) FS-2d |  | 19.38d | 0d | as late as possible | TB26 - 3 - Construction Normal 7days * CA17 |  |  |  | MTA |  | XC40173605 | 0 | 0 | 934 | 17 | 200 | 200 | C | MO04 | X | C | XC40 | 1736 | C | 17 | X | pre | LND | 1736 |  |  |  |  |  | x | MO11 |  |  |  |  |  |  |  |  |
| XC40173620 |  | CA17 ExtrBldgFl5 - Concrete Works Roof +36m |  | 20d | 2011-12-21 | 2012-01-16 | XC40173015, IMS-C-000080 FF, XN201736 FS-10d, EC48173620 (other project) |  | -45d | 0d |  | TB26 - 3 - Construction Normal 7days * CA17 | Concrete works [330 cbm]; Concrete works [9900 h] | 8,011.71 | 9900,00 |  |  | XC40173620 | 9900 | 0 | 934 | 17 | 200 | 200 | C | MO04 | X | C | XC40 | 1736 | C | 17 | X | EB | LND | 1736 |  |  |  |  |  |  | MO11 | CA17 Heavy Lift | CA17 - critical - CW5 | C9-1 |  |  |  |  |  |
| XC40173610 |  | CA17 ExtrBldgFl5 - Concrete Works Col/Walls <36m (A-F/1-5) |  | 20d | 2011-12-26 | 2012-01-21 | XC40173020, XC40173010 FS-10d |  | -10d | 0d |  | TB26 - 3 - Construction Normal 7days * CA17 | Concrete works [167 cbm]; Concrete works [5010 h] | 21,596.15 | 12300,00 |  |  | XC40173610 | 5010 | 0 | 934 | 17 | 200 | 200 | C | MO04 | X | C | XC40 | 1736 | C | 17 | X | EB | LND | 1736 |  |  |  |  |  | x | MO11 |  |  |  |  |  |  |  |  |
| XC501736 |  | CA17 ExtrBldgFl5 - Finishing Works Rooms |  | 80d | 2012-01-17 | 2012-04-07 | IMS-C-000080 FF, P3S09S (other project) FF+10d, P3S06S (other project), EC501710 (other project) FS+20d, XC40173620, XC510C00 FS+15d |  | 16d | 0d |  | TB26 - 3 - Construction Normal 7days * CA17 | Finishing Works - Extrusion Building CA17 [33592 mhr]; Finishing Works - Extrusion building CA17 [33592 h] | 3,359,200 | 33592,00 | XC50 |  | XC501736 | 33592 | 0 | 934 | 17 | 200 | 200 | C | CiC | X | C | XC50 | 1736 | C | 17 | X | EB | LND | 1710 |  |  |  |  |  |  |  |  | CA17 - critical - CW5 |  | 1 | OD 120>80 |  |  |  |
| XC501736_1 |  | CA17 ExtrBldgFl5 - Plastering and Painting |  | 20d | 2012-01-17 | 2012-02-05 | XC501736 SS |  | 16d | 0d |  | TB26 - 3 - Construction Normal 7days * CA17 |  |  | 33592,00 |  |  | XC501736 | 33592 | 0 | 934 | 17 | 200 | 200 | C | CiC | X | C | XC50 | 1736 | C | 17 | X | EB | LND | 1710 |  |  |  |  |  |  |  |  | CA17 - critical - CW5 |  | 1 | OD 120>80 |  |  |  |
| XC40173615 |  | CA17 ExtrBldgFl5 - Erection Precast Elements Stairtowers <36m North/South |  | 10d | 2012-01-22 | 2012-01-31 | XC40173610, XC40173015, XC40173605 |  | 6d | 10d |  | TB26 - 3 - Construction Normal 7days * CA17 | Precast Concrete Works [60 cbm]; Precast concrete works [150 h] | 6,000 | 150,00 |  |  | XC40173615 | 150 | 0 | 934 | 17 | 200 | 200 | C | MO04 | X | C | XC40 | 1736 | C | 17 | X | EB | LND | 1736 |  |  |  |  |  | x | MO11 |  |  |  |  |  |  |  |  |
|  | N | **Structural Steel** |  |  | 2011-05-05 | 2012-03-07 |  |  |  |  |  |  |  |  |  |  |  |  |  |  |  |  |  |  |  |  |  |  |  |  |  |  |  |  |  |  |  |  |  |  |  |  |  |  |  |  |  |  |  |  |  |
| XN821701 |  | CA17 ExtrBldgFl5 SK1701- KMD Assy Drawings level 130 m | milestone | 0d | 2011-05-05 A | 2011-05-05 A |  | 100% |  |  | finish on 2011-05-05 | TB26 - 3 - Construction Normal 7days * CA17 |  |  | 22t |  |  | XN821701 | 0 | 0 | 934 | 17 | 200 | 200 | C | LND | X | N | XN05 | 1736 | N | 17 | X | SS | LND | 1736 |  |  |  |  |  |  |  |  |  | KMD |  |  | XNK |  |  |
| XN831701 |  | CA17 ExtrBldgFl5 SK1701 - Steel Deliveries level 130 m | milestone | 0d | 2011-05-13 A | 2011-05-13 A |  | 100% |  |  | finish on 2011-05-13 | TB26 - 3 - Construction Normal 7days * CA17 |  |  | 22t |  |  | XN831701 | 0 | 0 | 934 | 17 | 200 | 200 | C | LND | X | N | XN06 | 1736 | N | 17 | X | SS | LND | 1736 |  |  |  |  |  |  |  |  |  | SD |  |  | XNK |  |  |
| XN201736 |  | CA17 ExtrBldgFl5 SK1701- Erec Prim Steel+M.Sheets <36m |  | 25d | 2011-12-06 | 2011-12-30 | XN821701, XN831701 FS+10d, P3N025N (other project), XC40173020 FS-20d, XN201730 FS-10d, XC40173630 |  | -161d | 0d |  | TB26 - 3 - Construction Normal 7days * CA17 | Piperacks, Main Structures [276 t]; Piperacks, Main structures [11730 h] | 4,966.67 | 11730,00 |  |  | XN201736 | 11730 | 0 | 934 | 17 | 200 | 200 | C | LND | X | N | XN20 | 1736 | N | 17 | X | SS | LND | 1736 |  | E-04-16 |  | 2011-09-29 | 2011-10-24 |  | ChSK | CA17 Heavy Lift | CA17 - critical - CW5 | C9-1 |  |  | PU10 | t | 2DC8990 |
| XC701736 |  | CA17 ExtrBldgFl5 SK1701 - Install Supports Ceiling <36m |  | 50d | 2011-12-31 | 2012-02-26 | XC40173620 FS-10d |  | -45d | 4.5d |  | TB26 - 3 - Construction Normal 7days * CA17 | Piperacks, Main Structures [72 t]; Piperacks, Main structures [3060 h] |  | 3060,00 |  |  | XC701736 | 3060 | 0 | 934 | 17 | 200 | 200 | C | LND | X | C | XN70 | 1736 | N | 17 | X | SS | LND | 1736 |  |  |  |  |  |  | MO11 |  | CA17 - critical - CW5 |  |  |  | XNK |  |  |
| XN301736 |  | CA17 ExtrBldgFl5 SK1701 - Install Eqpt Platforms |  | 40d | 2011-12-31 | 2012-02-15 | XN201736, XN821701, XN831701 FS+10d |  | -40.12d | 0d |  | TB26 - 3 - Construction Normal 7days * CA17 | Ladders & platforms | 1,123.41 | 0,00 |  |  | XN301736 | 0 | 0 | 934 | 17 | 200 | 200 | C | LND | X | N | XN30 | 1736 | N | 17 | X | SS | LND | 1736 |  |  |  |  |  |  | ChSK |  |  |  |  |  | XNK | t |  |
| XN801736 |  | CA17 ExtrBldgFl5 SK1701 - Install Cladding |  | 60d | 2011-12-31 | 2012-03-07 | XN201736, EN801711 (other project), P3N02§N (other project), P3N03N (other project) |  | -29d | 20.5d |  | TB26 - 3 - Construction Normal 7days * CA17 | Cladding [1380 sqm]; Cladding [6900 h] | 2,266.04 | 6900,00 |  |  | XN801736 | 6900 | 0 | 934 | 17 | 200 | 200 | C | LND | X | N | XN80 | 1736 | N | 17 | X | SS | LND | 1736 |  |  |  |  |  |  | ChSK |  | CA17 - critical - CW5 |  |  | OD 70>60 | XNK |  |  |
| XN401736 |  | CA17 ExtrBldgFl5 SK1701- Install Railings,Ladders,etc. |  | 40d | 2012-01-15 | 2012-02-24 | XN301736 FF+8d, XN201736 SS+20d, EC701710 (other project) |  | -7d | 0d |  | TB26 - 3 - Construction Normal 7days * CA17 | Ladders & platforms | 155.21 | 0,00 |  |  | XN401736 | 0 | 0 | 934 | 17 | 200 | 200 | C | LND | X | N | XN40 | 1736 | N | 17 | X | SS | LND | 1736 |  |  |  |  |  |  | ChSK |  |  |  |  |  | XNK |  |  |
| XN601736 |  | CA17 ExtrBldgFl5 SK1701 - Install Gratings |  | 40d | 2012-01-20 | 2012-02-29 | XN401736 FF+5d, PN691736 (other project) |  | -7d | 42.5d |  | TB26 - 3 - Construction Normal 7days * CA17 | Grating [300 sqm]; Grating [1125 h] | 8,639.94 | 1125,00 |  |  | XN601736 | 1125 | 0 | 934 | 17 | 200 | 200 | C | LND | X | N | XN60 | 1736 | N | 17 | X | SS | LND | 1736 |  |  |  |  |  |  | ChSK |  |  |  |  |  | XNK |  |  |

Notes:
- XW501730: P3 Activity Log Info: Clarification Surface / Protection during Prefab
- XN831701: Scope: 09.02.2011: weight: 460 ton
- XN201736: Scope: 15.02.2011 (O.Siegel): die Liefermenge fьr Level 130m / belдuft sich auf 460 t. Da die Eqpt-Platforms 40 t wiegen, Support Ceiling / 40 t wiegt, bleiben fьr Prim Steel 380 t.
- XC701736: Scope: 15.02.2011 (O.Siegel): die Liefermenge fьr Level 130m / belдuft sich auf 460 t. Da die Eqpt-Platforms 40 t wiegen, Support Ceiling / 40 t wiegt, bleiben fьr Prim Steel 380 t.
- XN301736: Scope: 15.02.2011 (O.Siegel): die Liefermenge fьr Level 130m / belдuft sich auf 460 t. Da die Eqpt-Platforms 40 t wiegen, Support Ceiling / 40 t wiegt, bleiben fьr Prim Steel 380 t.

| ID | WBS | Activity | Type | Duration | Start | Finish | Predecessors | Total float | Free float | Constraint | Calendar | Resources | Cost | TB26 Ressource Budget | UDF_SELECT | UDF_Text4 | UDF_CONTRACT START DATE | UDF_CONTRACT FINISH DATE | UDF_CONTRACT DATE PENALIZED | UDF_CHECK CRITICAL PATH | UDF_L3 START DATE | UDF_L3 FINISH DATE | UDF_SAVE ACT ID | UDF_BUDGETED LABOR UNIT | UDF_ACTUAL LABOR UNIT | Department | Type of Work | Constr. Area | PMT-Area | PMT-Schedule Org | PMT-Phase | PMT-Respons. | WBS Phase | WBS Discipline | WBS Type of Work | WBS Objects | Russia WBS Discipline (Russia) | Russia Construction Area | Russia WBS Phase | IMS | UPT | Russia WBS Objects | Subcontractor | WEIGHT | UDF_LEVEL | UDF_TAG No | UDF_Object No | UDF_PACKAGE | UDF_SUPPLIER | UDF_Vendor Representatives | Zeigen/n. Zeigen | UDF_Weight (ton) | POSITION | UDF_CONTRACT ITEM | Inquiry/Order No | UDF_CHECK BASELINE |
| --- | --- | --- | --- | --- | --- | --- | --- | --- | --- | --- | --- | --- | --- | --- | --- | --- | --- | --- | --- | --- | --- | --- | --- | --- | --- | --- | --- | --- | --- | --- | --- | --- | --- | --- | --- | --- | --- | --- | --- | --- | --- | --- | --- | --- | --- | --- | --- | --- | --- | --- | --- | --- | --- | --- | --- | --- |
|  | H | **HVAC** |  |  | 2012-02-06 | 2012-06-29 |  |  |  |  |  |  |  |  |  |  |  |  |  |  |  |  |  |  |  |  |  |  |  |  |  |  |  |  |  |  |  |  |  |  |  |  |  |  |  |  |  |  |  |  |  |  |  |  |  |  |
| XH00173605 |  | CA17 ExtrBldgFl5 - Installation HVAC |  | 70d | 2012-02-06 | 2012-04-17 | XC40173620, XH000000 FF, XC701736 FF+10d, P3H01SM (other project), XN801736 FF+10d, EH30173605 (other project), XC501736_1 | 16d | 0d |  | TB26 - 3 - Construction Normal 7days * CA17 | HVAC - Extrusion building CA17 [10283 h]; HVAC - Extrusion Building CA17 [10283 mhr] |  | 10283,00 | REL XC50 | CA17 - critical - CW5 | 2011-11-10 | 2011-11-10 | P | OD 100>70 | 2011-08-02 | 2011-10-22 | XH00173605 | 10283 | 0 | 934 | XBB | 17 | 200 | 200 | C | LND | X | H | XH00 | 1700 | H | 17 | X | hvac | LND | 1736 | ARMO |  |  |  |  |  |  |  |  |  |  |  |  |  |
| XH00173610 |  | CA17 ExtrBldgFl5 - Testing/Commissiong HVAC (w. temp. Power) |  | 70d | 2012-04-18 | 2012-06-29 | XH000010 FF, XH00173605, X0300008 FS+20d | 16d | 0d |  | TB26 - 3 - Construction Normal 7days * CA17 |  |  |  |  | CA17 - critical - CW5 | 2011-12-30 | 2011-12-30 | P | OD 70>60 | 2011-10-22 | 2011-12-19 | XH00173610 | 0 | 0 | 934 | XBB | 17 | 200 | 200 | C | LND | X | H | XH20 | 1736 | H | 17 | X | hvac | LND | 1736 | ARMO |  |  |  |  |  |  |  |  |  |  |  |  |  |
| XH00173607 |  | CA17 ExtrBldgFl5 - HVAC ready for Heating | milestone | 0d | 2012-04-28 | 2012-04-28 | XH00173610 SS+10d, XC501736 FS-15d | 333.5d | 146.5d |  | TB26 - 3 - Construction Normal 7days * CA17 |  |  | 4113 |  | CA17 - critical - CW5 |  |  |  |  | 2011-11-01 | 2011-11-01 | XH00173607 | 0 | 0 | 934 | XBB | 17 | 200 | 200 | C | LND | X | H | XH00 | 1736 | H | 17 | X | hvac | LND | 1736 | ARMO |  |  |  |  |  |  |  |  |  |  |  |  |  |
|  | U | **Package Units** |  |  |  |  |  |  |  |  |  |  |  |  |  |  |  |  |  |  |  |  |  |  |  |  |  |  |  |  |  |  |  |  |  |  |  |  |  |  |  |  |  |  |  |  |  |  |  |  |  |  |  |  |  |  |
|  | B | **Mechanical - Stationary Equipment** |  |  | 2011-09-26 | 2012-04-14 |  |  |  |  |  |  |  |  |  |  |  |  |  |  |  |  |  |  |  |  |  |  |  |  |  |  |  |  |  |  |  |  |  |  |  |  |  |  |  |  |  |  |  |  |  |  |  |  |  |  |
| DV-21401 |  | DIVERTER VALVE |  | 4d | 2011-09-26 | 2011-09-29 |  | 455.5d |  | start on or after 2011-09-26 |  | Static Equipment < 10 tons [0.2 t]; Static equipment < 10t [20 h] | 800 | 20,00 |  |  |  |  |  |  |  |  | DV-21401 | 20 | 0 |  |  | 17 |  |  |  |  | X | B |  | 1700 |  |  |  |  |  |  |  | 1000 | elev +15.00 | DV-21401 | SK1736 | PU02 ADDITIVE SYSTEM COMPONENTS (PK-21-/22401) | K-TRON | 018 | EQ |  |  |  |  |  |
| DV-21402 |  | DIVERTER VALVE |  | 4d | 2011-09-26 | 2011-09-29 |  | 455.5d |  | start on or after 2011-09-26 |  | Static Equipment < 10 tons [0.2 t]; Static equipment < 10t [20 h] | 800 | 20,00 |  |  |  |  |  |  |  |  | DV-21402 | 20 | 0 |  |  | 17 |  |  |  |  | X | B |  | 1700 |  |  |  |  |  |  |  | 1000 | elev +15.00 | DV-21402 | SK1736 | PU02 ADDITIVE SYSTEM COMPONENTS (PK-21-/22401) | K-TRON | 018 | EQ |  |  |  |  |  |
| DV-21403 |  | DIVERTER VALVE |  | 4d | 2011-09-26 | 2011-09-29 |  | 455.5d |  | start on or after 2011-09-26 |  | Static Equipment < 10 tons [0.2 t]; Static equipment < 10t [20 h] | 800 | 20,00 |  |  |  |  |  |  |  |  | DV-21403 | 20 | 0 |  |  | 17 |  |  |  |  | X | B |  | 1700 |  |  |  |  |  |  |  | 1000 | elev +15.00 | DV-21403 | SK1736 | PU02 ADDITIVE SYSTEM COMPONENTS (PK-21-/22401) | K-TRON | 018 | EQ |  |  |  |  |  |
| DV-21404 |  | DIVERTER VALVE |  | 4d | 2011-09-26 | 2011-09-29 |  | 455.5d |  | start on or after 2011-09-26 |  | Static Equipment < 10 tons [0.2 t]; Static equipment < 10t [20 h] | 800 | 20,00 |  |  |  |  |  |  |  |  | DV-21404 | 20 | 0 |  |  | 17 |  |  |  |  | X | B |  | 1700 |  |  |  |  |  |  |  | 1000 |  | DV-21404 | SK1736 | PU02 ADDITIVE SYSTEM COMPONENTS (PK-21-/22401) | K-TRON | 018 | EQ |  |  |  |  |  |
| DV-21405 |  | DIVERTER VALVE |  | 4d | 2011-09-26 | 2011-09-29 |  | 455.5d |  | start on or after 2011-09-26 |  | Static Equipment < 10 tons [0.2 t]; Static equipment < 10t [20 h] | 800 | 20,00 |  |  |  |  |  |  |  |  | DV-21405 | 20 | 0 |  |  | 17 |  |  |  |  | X | B |  | 1700 |  |  |  |  |  |  |  | 1000 |  | DV-21405 | SK1736 | PU02 ADDITIVE SYSTEM COMPONENTS (PK-21-/22401) | K-TRON | 018 | EQ |  |  |  |  |  |
| DV-21407 |  | DIVERTER VALVE |  | 4d | 2011-09-26 | 2011-09-29 |  | 455.5d |  | start on or after 2011-09-26 |  | Static Equipment < 10 tons [0.2 t]; Static equipment < 10t [20 h] | 800 | 20,00 |  |  |  |  |  |  |  |  | DV-21407 | 20 | 0 |  |  | 17 |  |  |  |  | X | B |  | 1700 |  |  |  |  |  |  |  | 1000 |  | DV-21407 | SK1736 | PU02 ADDITIVE SYSTEM COMPONENTS (PK-21-/22401) | K-TRON | 018 | EQ |  |  |  |  |  |
| DV-22401 |  | DIVERTER VALVE |  | 4d | 2011-09-26 | 2011-09-29 |  | 455.5d |  | start on or after 2011-09-26 |  | Static Equipment < 10 tons [0.2 t]; Static equipment < 10t [20 h] | 800 | 20,00 |  |  |  |  |  |  |  |  | DV-22401 | 20 | 0 |  |  | 17 |  |  |  |  | X | B |  | 1700 |  |  |  |  |  |  |  | 1000 |  | DV-22401 | SK1736 | PU02 ADDITIVE SYSTEM COMPONENTS (PK-21-/22401) | K-TRON | 018 | EQ |  |  |  |  |  |
| DV-22402 |  | DIVERTER VALVE |  | 4d | 2011-09-26 | 2011-09-29 |  | 455.5d |  | start on or after 2011-09-26 |  | Static Equipment < 10 tons [0.2 t]; Static equipment < 10t [20 h] | 800 | 20,00 |  |  |  |  |  |  |  |  | DV-22402 | 20 | 0 |  |  | 17 |  |  |  |  | X | B |  | 1700 |  |  |  |  |  |  |  | 1000 | elev +15.00 | DV-22402 | SK1736 | PU02 ADDITIVE SYSTEM COMPONENTS (PK-21-/22401) |  | 018 | EQ |  |  |  |  |  |
| DV-22403 |  | DIVERTER VALVE |  | 4d | 2011-09-26 | 2011-09-29 |  | 455.5d |  | start on or after 2011-09-26 |  | Static Equipment < 10 tons [0.2 t]; Static equipment < 10t [20 h] | 800 | 20,00 |  |  |  |  |  |  |  |  | DV-22403 | 20 | 0 |  |  | 17 |  |  |  |  | X | B |  | 1700 |  |  |  |  |  |  |  | 1000 | elev +15.00 | DV-22403 | SK1736 | PU02 ADDITIVE SYSTEM COMPONENTS (PK-21-/22401) |  | 018 | EQ |  |  |  |  |  |
| DV-22404 |  | DIVERTER VALVE |  | 4d | 2011-09-26 | 2011-09-29 |  | 455.5d |  | start on or after 2011-09-26 |  | Static Equipment < 10 tons [0.2 t]; Static equipment < 10t [20 h] | 800 | 20,00 |  |  |  |  |  |  |  |  | DV-22404 | 20 | 0 |  |  | 17 |  |  |  |  | X | B |  | 1700 |  |  |  |  |  |  |  | 1000 |  | DV-22404 | SK1736 | PU02 ADDITIVE SYSTEM COMPONENTS (PK-21-/22401) | K-TRON | 018 | EQ |  |  |  |  |  |
| DV-22405 |  | DIVERTER VALVE |  | 4d | 2011-09-26 | 2011-09-29 |  | 455.5d |  | start on or after 2011-09-26 |  | Static Equipment < 10 tons [0.2 t]; Static equipment < 10t [20 h] | 800 | 20,00 |  |  |  |  |  |  |  |  | DV-22405 | 20 | 0 |  |  | 17 |  |  |  |  | X | B |  | 1700 |  |  |  |  |  |  |  | 1000 | elev +15.00 | DV-22405 | SK1736 | PU02 ADDITIVE SYSTEM COMPONENTS (PK-21-/22401) |  | 018 | EQ |  |  |  |  |  |
| DV-22407 |  | DIVERTER VALVE |  | 4d | 2011-09-26 | 2011-09-29 |  | 455.5d |  | start on or after 2011-09-26 |  | Static Equipment < 10 tons [0.2 t]; Static equipment < 10t [20 h] | 800 | 20,00 |  |  |  |  |  |  |  |  | DV-22407 | 20 | 0 |  |  | 17 |  |  |  |  | X | B |  | 1700 |  |  |  |  |  |  |  | 1000 |  | DV-22407 | SK1736 | PU02 ADDITIVE SYSTEM COMPONENTS (PK-21-/22401) | K-TRON | 018 | EQ |  |  |  |  |  |
| BG-21401 |  | ADDITIVE BAG UNLOADING STATION |  | 15d | 2012-01-16 | 2012-02-02 | BG-21402 SS, XB001736 FF, BG-22401 SS, BG-22403 SS, BG-22404 SS, XC40173620, BG-21403 SS, BG-22405 SS, XB001736 SS, BG-21404 SS, BG-21407 SS, BG-21405 SS, BG-21408 SS, BG-22402 SS, BG-22407 SS, P3U02S2 (other project) | -1.88d | 0d |  |  | Static Equipment < 10 tons [1 t]; Static equipment < 10t [100 h] | 4,000 | 100,00 |  |  |  |  |  |  |  |  | BG-21401 | 100 | 0 |  |  | 17 |  |  |  |  | X | B |  | 1736 |  |  |  |  |  |  |  | 1000 | concrete +31.80 | BG-21401 | SK1736 | PU02 ADDITIVE SYSTEM COMPONENTS (PK-21-/22401) | K-TRON | 018 | EQ | 1 | a |  |  |  |
| BG-21402 |  | ADDITIVE BAG UNLOADING STATION |  | 15d | 2012-01-16 | 2012-02-02 | XB001736 FF, XC40173620, P3U02S2 (other project), XB001736 SS | -1.88d | 0d |  |  | Static Equipment < 10 tons [1 t]; Static equipment < 10t [100 h] | 4,000 | 100,00 |  |  |  |  |  |  |  |  | BG-21402 | 100 | 0 |  |  | 17 |  |  |  |  | X | B |  | 1736 |  |  |  |  |  |  |  | 1000 | concrete +31.80 | BG-21402 | SK1736 | PU02 ADDITIVE SYSTEM COMPONENTS (PK-21-/22401) | K-TRON | 018 | EQ | 1 | a |  |  |  |
| BG-21403 |  | ADDITIVE BAG UNLOADING STATION |  | 15d | 2012-01-16 | 2012-02-02 | P3U02S2 (other project), XC40173620, XB001736 FF, XB001736 SS | -1.88d | 0d |  |  | Static Equipment < 10 tons [1 t]; Static equipment < 10t [100 h] | 4,000 | 100,00 |  |  |  |  |  |  |  |  | BG-21403 | 100 | 0 |  |  | 17 |  |  |  |  | X | B |  | 1736 |  |  |  |  |  |  |  | 1000 | concrete +31.80 | BG-21403 | SK1736 | PU02 ADDITIVE SYSTEM COMPONENTS (PK-21-/22401) | K-TRON | 018 | EQ | 1 | a |  |  |  |
| BG-21404 |  | PEROXIDE BAG UNLOADING STATION |  | 15d | 2012-01-16 | 2012-02-02 | XB001736 SS, XB001736 FF, XC40173620, P3U02S2 (other project) | -1.88d | 0d |  |  | Static Equipment < 10 tons [1 t]; Static equipment < 10t [100 h] | 4,000 | 100,00 |  |  |  |  |  |  |  |  | BG-21404 | 100 | 0 |  |  | 17 |  |  |  |  | X | B |  | 1736 |  |  |  |  |  |  |  | 1000 | concrete +31.80 | BG-21404 | SK1736 | PU02 ADDITIVE SYSTEM COMPONENTS (PK-21-/22401) | K-TRON | 018 | EQ | 1 | a |  |  |  |
| BG-21405 |  | ADDITIVE BAG UNLOADING STATION |  | 15d | 2012-01-16 | 2012-02-02 | XC40173620, P3U02S2 (other project), XB001736 SS, XB001736 FF | -1.88d | 0d |  |  | Static Equipment < 10 tons [1 t]; Static equipment < 10t [100 h] | 4,000 | 100,00 |  |  |  |  |  |  |  |  | BG-21405 | 100 | 0 |  |  | 17 |  |  |  |  | X | B |  | 1736 |  |  |  |  |  |  |  | 1000 | concrete +31.80 | BG-21405 | SK1736 | PU02 ADDITIVE SYSTEM COMPONENTS (PK-21-/22401) | K-TRON | 018 | EQ | 1 | a |  |  |  |
| BG-21407 |  | PEROXIDE UNLOADING STATION |  | 15d | 2012-01-16 | 2012-02-02 | P3U02S2 (other project), XC40173620, XB001736 FF, XB001736 SS | -1.88d | 0d |  |  | Static Equipment < 10 tons [1 t]; Static equipment < 10t [100 h] | 4,000 | 100,00 |  |  |  |  |  |  |  |  | BG-21407 | 100 | 0 |  |  | 17 |  |  |  |  | X | B |  | 1736 |  |  |  |  |  |  |  | 1000 | concrete +31.80 | BG-21407 | SK1736 | PU02 ADDITIVE SYSTEM COMPONENTS (PK-21-/22401) | K-TRON | 018 | EQ | 1 | a |  |  |  |
| BG-21408 |  | TALC UNLOADING STATION |  | 15d | 2012-01-16 | 2012-02-02 | XC40173620, XB001736 SS, XB001736 FF, P3U02S2 (other project) | -1.88d | 0d |  |  | Static Equipment < 10 tons [1 t]; Static equipment < 10t [100 h] | 4,000 | 100,00 |  |  |  |  |  |  |  |  | BG-21408 | 100 | 0 |  |  | 17 |  |  |  |  | X | B |  | 1736 |  |  |  |  |  |  |  | 1000 | concrete +31.80 | BG-21408 | SK1736 | PU02 ADDITIVE SYSTEM COMPONENTS (PK-21-/22401) | K-TRON | 018 | EQ | 1 | a |  |  |  |
| BG-22401 |  | ADDITIVE BAG UNLOADING STATION |  | 15d | 2012-01-16 | 2012-02-02 | XC40173620, XB001736 FF, XB001736 SS, P3U02S2 (other project) | -1.88d | 0d |  |  | Static Equipment < 10 tons [1 t]; Static equipment < 10t [100 h] | 4,000 | 100,00 |  |  |  |  |  |  |  |  | BG-22401 | 100 | 0 |  |  | 17 |  |  |  |  | X | B |  | 1736 |  |  |  |  |  |  |  | 1000 | concrete +31.80 | BG-22401 | SK1736 | PU02 ADDITIVE SYSTEM COMPONENTS (PK-21-/22401) | K-TRON | 018 | EQ | 1 | a |  |  |  |
| BG-22402 |  | ADDITIVE BAG UNLOADING STATION |  | 15d | 2012-01-16 | 2012-02-02 | XB001736 SS, XB001736 FF, P3U02S2 (other project), XC40173620 | -1.88d | 0d |  |  | Static Equipment < 10 tons [1 t]; Static equipment < 10t [100 h] | 4,000 | 100,00 |  |  |  |  |  |  |  |  | BG-22402 | 100 | 0 |  |  | 17 |  |  |  |  | X | B |  | 1736 |  |  |  |  |  |  |  | 1000 | concrete +31.80 | BG-22402 | SK1736 | PU02 ADDITIVE SYSTEM COMPONENTS (PK-21-/22401) | K-TRON | 018 | EQ | 1 | a |  |  |  |
| BG-22403 |  | ADDITIVE BAG UNLOADING STATION |  | 15d | 2012-01-16 | 2012-02-02 | XB001736 FF, P3U02S2 (other project), XC40173620, XB001736 SS | -1.88d | 0d |  |  | Static Equipment < 10 tons [1 t]; Static equipment < 10t [100 h] | 4,000 | 100,00 |  |  |  |  |  |  |  |  | BG-22403 | 100 | 0 |  |  | 17 |  |  |  |  | X | B |  | 1736 |  |  |  |  |  |  |  | 1000 | concrete +31.80 | BG-22403 | SK1736 | PU02 ADDITIVE SYSTEM COMPONENTS (PK-21-/22401) | K-TRON | 018 | EQ | 1 | a |  |  |  |
| BG-22404 |  | PEROXIDE BAG UNLOADING STATION |  | 15d | 2012-01-16 | 2012-02-02 | XC40173620, XB001736 SS, P3U02S2 (other project), XB001736 FF | -1.88d | 0d |  |  | Static Equipment < 10 tons [1 t]; Static equipment < 10t [100 h] | 4,000 | 100,00 |  |  |  |  |  |  |  |  | BG-22404 | 100 | 0 |  |  | 17 |  |  |  |  | X | B |  | 1736 |  |  |  |  |  |  |  | 1000 | concrete +31.80 | BG-22404 | SK1736 | PU02 ADDITIVE SYSTEM COMPONENTS (PK-21-/22401) | K-TRON | 018 | EQ | 1 | a |  |  |  |
| BG-22405 |  | ADDITIVE BAG UNLOADING STATION |  | 15d | 2012-01-16 | 2012-02-02 | XC40173620, XB001736 SS, P3U02S2 (other project), XB001736 FF | -1.88d | 0d |  |  | Static Equipment < 10 tons [1 t]; Static equipment < 10t [100 h] | 4,000 | 100,00 |  |  |  |  |  |  |  |  | BG-22405 | 100 | 0 |  |  | 17 |  |  |  |  | X | B |  | 1736 |  |  |  |  |  |  |  | 1000 | concrete +31.80 | BG-22405 | SK1736 | PU02 ADDITIVE SYSTEM COMPONENTS (PK-21-/22401) | K-TRON | 018 | EQ | 1 | a |  |  |  |
| BG-22407 |  | PEROXIDE UNLOADING STATION |  | 15d | 2012-01-16 | 2012-02-02 | XC40173620, P3U02S2 (other project), XB001736 SS, XB001736 FF | -1.88d | 0d |  |  | Static Equipment < 10 tons [1 t]; Static equipment < 10t [100 h] | 4,000 | 100,00 |  |  |  |  |  |  |  |  | BG-22407 | 100 | 0 |  |  | 17 |  |  |  |  | X | B |  | 1736 |  |  |  |  |  |  |  | 1000 | concrete +31.80 | BG-22407 | SK1736 | PU02 ADDITIVE SYSTEM COMPONENTS (PK-21-/22401) | K-TRON | 018 | EQ | 1 | a |  |  |  |
| XB001736 |  | CA17 ExtrBldgFl5 - Install Static Eqpt | level of effort | 86.5d | 2012-01-17 | 2012-04-14 |  | -49.62d | 0d |  | TB26 - 3 - Construction Normal 7days * CA17 |  |  | 26 | OMUS-1 |  | 2011-07-30 | 2011-10-10 |  |  |  |  | XB001736 | 0 | 0 | 934 | PU10 | 17 | 200 | 200 | C | LND | X | B | XB00 | 1736 | B | 17 | X | EQ | LND | 1736 |  |  |  |  | SK1736 |  |  |  |  |  |  | E-08-01-16 | 2DC8990 |  |
| MI-21401-SE01 |  | DEWATERING SCREEN |  | 15d | 2012-02-16 | 2012-03-05 | XB001736 FF, XB001736 SS, XN301736, P3M01SB (other project), XC40173620, P3M01SA (other project), P3M01SC (other project) | -34.12d | 0d |  |  | Extruder [10.85 mhr]; Extruder [10.85 h] | 1,085 | 10,85 |  |  |  |  |  |  |  |  | MI-21401-SE01 | 10,85 | 0 |  |  | 17 |  |  |  |  | X | B |  | 1710 |  |  |  |  |  |  |  | 1085 | elev +35.00 | MI-21401-SE01 | SK1736 | M01 EXTRUDER (EX-21-/22401) |  |  | EQ | 1,9 | a |  |  |  |
| DV-21441 |  | DIVERTER VALVE |  | 15d | 2012-03-01 | 2012-03-19 | XC40173620, P3M01SC (other project), XB001736 SS, P3M01SB (other project), XN301736, XB001736 FF, MI-21401 SS, P3M01SA (other project) | -35.12d | 0d |  |  | Extruder |  | 0,00 |  |  |  |  |  |  |  |  | DV-21441 | 0 | 0 |  |  | 17 |  |  |  |  | X | B |  | 1710 |  |  |  |  |  |  |  | 13000 | elev +34.907 | DV-21442 | SK1736 | M01 EXTRUDER (EX-21-/22401) |  |  | EQ | 0 | a |  |  | missing CB |
| DV-21442 |  | DIVERTER VALVE |  | 15d | 2012-03-01 | 2012-03-19 | MI-21401 SS, P3M01SB (other project), DV-21441 SS, P3M01SA (other project), XB001736 SS, XC40173620, XB001736 FF, XN301736, P3M01SC (other project) | -35.12d | 0d |  |  | Extruder [130 mhr]; Extruder [130 h] | 13,000 | 130,00 |  |  |  |  |  |  |  |  | DV-21442 | 130 | 0 |  |  | 17 |  |  |  |  | X | B |  | 1710 |  |  |  |  |  |  |  | 13000 | concrete +31.80 | DV-21442 | SK1736 | M01 EXTRUDER (EX-21-/22401) |  |  | EQ | 13 | a |  |  |  |
| MI-21401 |  | PELLET DRYER |  | 15d | 2012-03-01 | 2012-03-19 | XB001736 SS, XC40173620, P3M01SA (other project), P3M01SB (other project), XB001736 FF, MI-21401-SE01 SS, XN301736, P3M01SC (other project) | -42.62d | 0d | start on or after 2012-03-01 |  | Extruder [34 mhr]; Extruder [34 h] | 3,400 | 34,00 |  |  |  |  |  |  |  |  | MI-21401 | 34 | 0 |  |  | 17 |  |  |  |  | X | B |  | 1710 |  |  |  |  |  |  |  | 3400 | structure +32.650 | MI-21401 | SK1736 | M01 EXTRUDER (EX-21-/22401) |  |  | EQ | 3,4 | a |  |  |  |
| MI-22401 |  | PELLET DRYER |  | 15d | 2012-03-06 | 2012-03-23 | XB001736 SS, P3M01SB (other project), XB001736 FF, XC40173620, P3M01SA (other project), XN301736, MI-22401-SE01 SS, P3M01SC (other project) | -34.12d | 0d | start on or after 2012-03-01 |  | Extruder [34 h]; Extruder [34 mhr] | 3,400 | 34,00 |  |  |  |  |  |  |  |  | MI-22401 | 34 | 0 |  |  | 17 |  |  |  |  | X | B |  | 1710 |  |  |  |  |  |  |  | 3400 | structure +32.650 | MI-22401 | SK1736 | M01 EXTRUDER (EX-21-/22401) |  |  | EQ | 3,4 | a |  |  |  |
| MI-22401-SE01 |  | DEWATERING SCREEN |  | 15d | 2012-03-06 | 2012-03-23 | P3M01SC (other project), XC40173620, XB001736 FF, XB001736 SS, MI-21401-SE01, XN301736, P3M01SA (other project), P3M01SB (other project) | -34.12d | 0d |  |  | Extruder [10.85 mhr]; Extruder [10.85 h] | 1,085 | 10,85 |  |  |  |  |  |  |  |  | MI-22401-SE01 | 10,85 | 0 |  |  | 17 |  |  |  |  | X | B |  | 1710 |  |  |  |  |  |  |  | 1085 | elev +35.00 | MI-22401-SE01 | SK1736 | M01 EXTRUDER (EX-21-/22401) |  |  | EQ | 1,085 | a |  |  |  |
| BG-21435 |  | BAG UNLOADING STATION |  | 15d | 2012-03-20 | 2012-04-05 | XN301736, XB001736 SS, XC40173620, P3U10S1A (other project), MI-21401, XB001736 FF | -42.62d | 0d |  |  | Static Equipment < 10 tons [0.5 t]; Static equipment < 10t [50 h] | 2,000 | 50,00 |  |  |  |  |  |  |  |  | BG-21435 | 50 | 0 |  |  | 17 |  |  |  |  | X | B |  | 1736 |  |  |  |  |  |  |  | 500 | concrete +31.80 | BG-21435 | SK1736 | PU10 CONVEYING SYSTEM (PK-21501) ZEPPELIN | ZEPPELIN | Zeppelin | EQ | 0,5 | a |  |  |  |
| DV-22441 |  | DIVERTER VALVE |  | 15d | 2012-03-20 | 2012-04-05 | XC40173620, DV-21442, P3M01SA (other project), XN301736, P3M01C (other project), P3M01SB (other project), XB001736 SS, DV-21441, MI-22401 SS, XB001736 FF | -35.12d | 0d |  |  | Extruder [130 mhr]; Extruder [130 h] | 13,000 | 130,00 |  |  |  |  |  |  |  |  | DV-22441 | 130 | 0 |  |  | 17 |  |  |  |  | X | B |  | 1710 |  |  |  |  |  |  |  | 13000 | elev +34.907 | DV-22441 | SK1736 | M01 EXTRUDER (EX-21-/22401) |  |  | EQ | 0 | a |  |  |  |
| DV-22442 |  | DIVERTER VALVE |  | 15d | 2012-03-20 | 2012-04-05 | XN301736, XB001736 SS, DV-21441, DV-22441 SS, P3M01SA (other project), P3M01SC (other project), P3M01SB (other project), DV-21442, MI-22401 SS, XB001736 FF, XC40173620 | -35.12d | 7.5d |  |  | Extruder [130 h]; Extruder [130 mhr] | 13,000 | 13,00 |  |  |  |  |  |  |  |  | DV-22442 | 130 | 0 |  |  | 17 |  |  |  |  | X | B |  | 1710 |  |  |  |  |  |  |  | 13000 | elev +32.30 | DV-22442 | SK1736 | M01 EXTRUDER (EX-21-/22401) |  |  | EQ | 13 | a |  |  |  |
| MB-21401 |  | BAG COMPACTOR |  | 10d | 2012-04-03 | 2012-04-14 | RF-21435, XC40173620, XN301736, XB001736 SS, P3U02S2 (other project), XC40173620 FF, MI-22401, XB001736 FF, MI-21401 | -42.62d | 0d |  |  | Static Equipment < 10 tons [0.6 t]; Static equipment < 10t [60 h] | 2,400 | 60,00 |  |  |  |  |  |  |  |  | MB-21401 | 60 | 0 |  |  | 17 |  |  |  |  | X | B |  | 1736 |  |  |  |  |  |  |  | 600 | concrete +31.650 | MB-21401 | SK1736 | PU02 ADDITIVE SYSTEM COMPONENTS (PK-21-/22401) |  |  | EQ | 0,6 | a |  |  |  |
| MB-22401 |  | BAG COMPACTOR |  | 10d | 2012-04-03 | 2012-04-14 | XN301736, P3U02S2 (other project), XC40173620, MB-21401 SS, XB001736 SS, RF-21435, XB001736 FF, XC40173620 FF | -42.62d | 0d |  |  | Static Equipment < 10 tons [0.6 t]; Static equipment < 10t [60 h] | 2,400 | 60,00 |  |  |  |  |  |  |  |  | MB-22401 | 60 | 0 |  |  | 17 |  |  |  |  | X | B |  | 1736 |  |  |  |  |  |  |  | 600 | concrete +31.650 | MB-22401 | SK1736 | PU02 ADDITIVE SYSTEM COMPONENTS (PK-21-/22401) |  |  | EQ | 0,6 | a |  |  |  |

Notes:
- XH00173605: Current Status: Delete XC501736 CA17 ExtrBldgFl5 - Finishing Works / Rooms

| ID | WBS | Activity | Duration | Start | Finish | Predecessors | Total float | Free float | Constraint | Calendar | Resources | Cost | TB26 Ressource Budget | UDF_Weight (ton) | POSITION | WEIGHT | UDF_LEVEL | UDF_PO No | UDF_TAG No | UDF_Object No | UDF_DELIVERY DATE PO | UDF_DELIVERY DATE DISPATCH PLANNED | UDF_DELIVERY DATE TO SITE PLANNED | UDF_DELIVERY DATE SITE NEED DATE | UDF_PACKAGE | UDF_SUPPLIER | UDF_Vendor Representatives | UDF_SAVE ACT ID | UDF_BUDGETED LABOR UNIT | UDF_ACTUAL LABOR UNIT | Constr. Area | Zeigen/n. Zeigen | WBS Phase | WBS Discipline | WBS Objects | UDF_SELECT | UDF_SELECT UPDATE PROGRESS | UDF_COMMENTS_0827 | Department | Type of Work | Inquiry/Order No | PMT-Area | PMT-Schedule Org | PMT-Phase | PMT-Respons. | WBS Type of Work | Russia WBS Discipline (Russia) | Russia Construction Area | Russia WBS Phase | IMS | UPT | Russia WBS Objects | UDF_CONTRACT START DATE | UDF_CONTRACT FINISH DATE | UDF_CONTRACT ITEM | UDF_PLANNED START | UDF_PLANNED FINISH | Subcontractor | UDF_PENALIZED FINISH | UDF_CONTRACT FINISH DATE REV1 | UDF_CONTRACT START DATE REV1 | UDF_INDICATOR | TB26 Semantics | TB26 Material Res Values | UDF_ELECTRICAL START | UDF_ELECTRICAL FINISH | UDF_CHECK BASELINE |
| --- | --- | --- | --- | --- | --- | --- | --- | --- | --- | --- | --- | --- | --- | --- | --- | --- | --- | --- | --- | --- | --- | --- | --- | --- | --- | --- | --- | --- | --- | --- | --- | --- | --- | --- | --- | --- | --- | --- | --- | --- | --- | --- | --- | --- | --- | --- | --- | --- | --- | --- | --- | --- | --- | --- | --- | --- | --- | --- | --- | --- | --- | --- | --- | --- | --- | --- | --- |
|  | M | **Mechanical - Rotating Equipment** |  | 2012-02-02 | 2012-03-20 |  |  |  |  |  |  |  |  |  |  |  |  |  |  |  |  |  |  |  |  |  |  |  |  |  |  |  |  |  |  |  |  |  |  |  |  |  |  |  |  |  |  |  |  |  |  |  |  |  |  |  |  |  |  |  |  |  |  |  |  |  |  |
| RF-21451 |  | PP POWDER VENT ROTARY FEEDER | 10d | 2012-02-02 | 2012-02-14 | XB001736 FF, XB001736 SS, BG-21408, P3U22S1 (other project), BG-21404 | 7d | 49.62d |  |  | Static Equipment < 10 tons [2.6 t]; Static equipment < 10t [260 h] | 10,400 | 260,00 | 2,6 | a | 2600 | concrete +31.800 | 2DC9170 | RF-21451 | SK1736 | 2010-10-05 | 2011-01-15 | 2011-01-27 | 2011-04-01 | PU22 VENT COLLECTION AND VACUUM SYSTEM | Zeppelin | 030 | RF-21451 | 260 | 0 | 17 | EQ | X | B | 1736 |  |  |  |  |  |  |  |  |  |  |  |  |  |  |  |  |  |  |  |  |  |  |  |  |  |  |  |  |  |  |  |  |
| BL-21452 |  | VACUUM SYSTEM FAN | 10d | 2012-03-09 | 2012-03-20 | XN301730, XC40173620, P3U22S1 (other project), F-21452, XN601730 | -30d | 0d |  |  | Static Equipment < 10 tons [2 t]; Static equipment < 10t [200 h] | 8,000 | 200,00 | 2 | a | 2000 | concrete +25.315 (roof) |  | BL-21452 | SK1736 |  |  |  |  | PU22 VENT COLLECTION AND VACUUM SYSTEM |  |  | BL-21452 | 200 | 0 | 17 | EQ | X | B | 1730 |  |  |  |  |  |  |  |  |  |  |  |  |  |  |  |  |  |  |  |  |  |  |  |  |  |  |  |  |  |  |  |  |
|  | R | **Piping** |  | 2011-09-15 | 2012-06-09 |  |  |  |  |  |  |  |  |  |  |  |  |  |  |  |  |  |  |  |  |  |  |  |  |  |  |  |  |  |  |  |  |  |  |  |  |  |  |  |  |  |  |  |  |  |  |  |  |  |  |  |  |  |  |  |  |  |  |  |  |  |  |
| XR201736 |  | CA17 ExtrBldgFl5 - Piping Prefabrication | 110d | 2011-09-15 | 2012-01-10 | ER49173605 (other project) SS+12d, ER491736 (other project) SS+12d, XR500C00 FS+15d | 37d | 0d | start on or after 2011-09-15 | TB26 - 3 - Construction Normal 7days * CA17 | A/G piping prefabrication [1880 Fpi]; Conveying S. piping prefabrication [100 Fpi]; A/G Piping (Prefab) [7050 h]; Conveying system (Prefab) [250 h] | 20,602.22 | 7300,00 |  |  |  |  |  |  |  |  |  |  |  |  |  |  | XR201736 | 7300 | 0 | 17 |  | X | R | 1736 | OMUS-1 | 27.8. | Start mid of sept | 934 | PU10 | 2DC8990 | 200 | 200 | C | LND | XR20 | R | 17 | X | PRP | LND | 1736 |  |  |  |  |  |  |  |  |  |  |  |  |  |  |  |
| XR401736 |  | CA17 ExtrBldgFl5 - Piping Installation | 90d | 2012-02-06 | 2012-05-10 | BG-21401 FF+20d, BG-21402 FF+20d, BG-22401 FF+20d, BG-22402 FF+20d, BG-22405 FF+20d, SE-22402 FF+20d, RF-22451 FF+20d, RF-21434 FF+20d, BG-21403 FF+20d, MI-22401 FF+20d, IMS-C-000190 FF, RF-21435 FF+20d, BG-21405 FF+20d, BG-21435 FF+20d, DV-22442 FF+20d, MB-21401 FF+20d, MI-21401 FF+20d, XR201736 FF+10d, BG-21404 FF+20d, DV-22441 FF+20d, BG-22403 FF+20d, BG-22404 FF+20d, P3J02AS (other project), DV-21441 FF+20d, MB-22401 FF+20d, BG-22407 FF+20d, MI-22401-SE01 FF+20d, P3J01AS (other project), P3J02S (other project), P3J02DS (other project), SE-21402 FF+20d, BG-21407 FF+20d, BG-21408 FF+20d, DV-21442 FF+20d, MI-21401-SE01 FF+20d, XC701736 FS-24d, XN801736 SS, RF-21451 FF+20d, P3S06S (other project), XN601736 FF+25d, XR201736 SS+50d | -49.5d | 0d |  | TB26 - 3 - Construction Normal 7days * CA17 | A/G piping field installation [1740 Fpi]; Conveying S. piping field installation [110 Fpi]; Control & Shut-off valves [26 pcs]; A/G Piping (Field) [10875 h]; Conveying system (Field) [550 h]; Install Control & Shut-off Valves [136.5 h] | 59,653.49 | 11561,50 |  |  |  |  |  |  |  |  |  |  |  |  |  |  | XR401736 | 11561,5 | 0 | 17 |  | X | R | 1736 | OMUS-1 |  |  | 934 | PU10 | 2DC8990 | 200 | 200 | C | LND | XR40 | R | 17 | X | PI | LND | 1736 | 2011-02-25 | 2012-02-25 | E-06-03-07 | 2011-05-12 |  |  |  |  |  |  |  |  |  |  |  |
| XR601736 |  | CA17 ExtrBldgFl5 - Piping Pressure Tests | 50d | 2012-04-08 | 2012-05-30 | XR401736 SS+40d, XR401736 FF+20d | -49.5d | 0d |  | TB26 - 3 - Construction Normal 7days * CA17 |  |  | 1241 |  |  |  |  |  |  |  |  |  |  |  |  |  |  | XR601736 | 0 | 0 | 17 |  | X | R | 1736 | OMUS-1 |  |  | 934 |  | 2DC8990 | 200 | 200 | C | LND | XR60 | R | 17 | X | HY | LND | 1736 | 2011-02-25 | 2012-02-25 | E-06-03-07 |  |  |  |  |  |  |  |  |  |  |  |  |
| XR801736 |  | CA17 ExtrBldgFl5 - Piping Reinstatement | 30d | 2012-05-10 | 2012-06-09 | IMS-C-000360 FF, XR601736 FF+10d | -49.5d | 0d |  | TB26 - 3 - Construction Normal 7days * CA17 |  |  | 620 |  |  |  |  |  |  |  |  |  |  |  |  |  |  | XR801736 | 0 | 0 | 17 |  | X | R | 1736 | OMUS-1 |  |  | 934 |  |  | 200 | 200 | C | LND | XR80 | R | 17 | X | PI | LND | 1736 | 2011-02-25 | 2012-02-25 | E-06-03-07 |  | 2012-05-11 |  |  |  |  |  |  |  |  |  |  |
|  | E | **Electrical** |  | 2011-12-01 | 2012-10-09 |  |  |  |  |  |  |  |  |  |  |  |  |  |  |  |  |  |  |  |  |  |  |  |  |  |  |  |  |  |  |  |  |  |  |  |  |  |  |  |  |  |  |  |  |  |  |  |  |  |  |  |  |  |  |  |  |  |  |  |  |  |  |
| XC911736 |  | CA17 ExtrBldgFl5 - Install Earthing&Lightn.Sys_CIVIL | 40d | 2011-12-01 | 2012-01-16 | XC40173620 FF, EE901736 (other project) | 41d | 65.5d |  | TB26 - 3 - Construction Normal 7days * CA17 | Grounding & Lightning [240 pcs]; Grounding & Lightning [2700 h] | 108,000 | 2700,00 |  |  |  |  |  |  |  |  |  |  |  |  |  |  | XC911736 | 2700 | 0 | 17 |  | X | C | 1736 |  |  |  | 934 |  |  | 200 | 200 | C | LND | XE91 | C | 17 | X | EA | LND | 1736 | 2011-09-20 | 2012-03-20 | E-16-07-10 |  |  | MO11 |  |  |  |  |  |  |  |  |  |
| XE911737 |  | CA17 ExtrBldgFl5 - Install Earthing&Lightn.Sys_E/I | 26d | 2012-03-24 | 2012-04-18 | XN301736, MI-22401 | 70d | 181.5d |  | TB26 - 3 - Construction Normal 7days * CA17 |  |  | 265 |  |  |  |  |  |  |  |  |  |  |  |  |  |  | XE911737 | 0 | 0 | 17 |  | X | E | 1736 |  |  |  | 934 |  |  | 200 | 200 | C | LND | XE91 | E | 17 | X | EA | LND | 1736 | 2011-09-20 | 2012-03-20 | E-16-07-10 |  |  | URMA | 2012-08-15 | 2012-08-15 | 2012-01-01 | UDF_G3 |  |  |  |  |  |
| XE341736 |  | CA17 ExtrBldgFl5 - Install Local Operation Panels | 50d | 2012-03-29 | 2012-05-20 | XE401736 FF, EE46173610 (other project), MI-22401, XR401736 FS-40d | 313d |  |  | TB26 - 3 - Construction Normal 7days * CA17 | Field Panels [11 pcs]; Field panels [220 h] | 8,800 | 220,00 |  |  |  |  |  |  |  |  |  |  |  |  |  |  | XE341736 | 220 | 0 | 17 |  | X | E | 1736 |  |  |  | 934 |  |  | 200 | 200 | C | LND | XE34 | E | 17 | X | EL | LND | 1736 | 2011-09-20 | 2012-03-20 | E-16-07-10 |  |  | URMA | 2012-08-15 | 2012-08-15 | 2012-01-01 | UDF_G3 |  |  |  |  |  |
| XE401736 |  | CA17 ExtrBldgFl5 - Install Cable Trays | 40d | 2012-03-29 | 2012-05-10 | EE46173610 (other project), XN801736, XR401736 FS-40d, XN301736 | -49.5d | 0d |  | TB26 - 3 - Construction Normal 7days * CA17 | Cable trays/conduits [480 m]; Cable trays [1440 h] | 57,600 | 1440,00 |  |  |  |  |  |  |  |  |  |  |  |  |  |  | XE401736 | 1440 | 0 | 17 |  | X | E | 1736 |  |  |  | 934 |  |  | 200 | 200 | C | LND | XE40 | E | 17 | X | EL | LND | 1736 | 2011-06-10 | 2011-11-30 | E-15-01-11 |  |  | URMA |  | 2012-04-01 | 2011-09-20 | UDF_G3 | m | 1200 | 2011-11-18 | 2012-02-12 | x |
| XE701736 |  | CA17 ExtrBldgFl5 - Install Lighting &Small Power | 50d | 2012-04-28 | 2012-06-20 | XE401736 FS-10d, P3E03S2 (other project) FF+20d, P3E09S (other project), EE76510110 (other project) FF+20d, XH00173605 SS+20d, EE761700 (other project), XP341610 FS+50d, EE76170010 (other project) FF+20d, XC501736 FS-30d | 10.5d | 122d |  | TB26 - 3 - Construction Normal 7days * CA17 | Lighting illuminates [150 pcs]; Lighting (iluminates) [1500 h] | 60,000 | 1500,00 |  |  |  |  |  |  |  |  |  |  |  |  |  |  | XE701736 | 1500 | 0 | 17 |  | X | E | 1736 |  |  |  | 934 |  |  | 200 | 200 | C | LND | XE70 | E | 16 | X | EL | LND | 1610 | 2011-05-10 | 2012-01-31 | E-16-03-01 |  |  | URMA |  | 2012-05-10 | 2011-08-15 | UDF_G3 |  |  |  |  |  |
| XE801736 |  | CA17 ExtrBldgFl5 - Install Heat Tracing | 40d | 2012-05-10 | 2012-06-20 | P3E19S (other project), RF-21434 FF+30d, IMS-C-000280 FF, E3E1950 (other project), XR401736 FS-40d, XR601736 FS-20d | -21.5d | 0d |  | TB26 - 3 - Construction Normal 7days * CA17 | Electrical Heat Tracing [900 m]; Electrical heat tracing [450 h] | 18,000 | 450,00 |  |  |  |  |  |  |  |  |  |  |  |  |  | 005 | XE801736 | 450 | 0 | 17 |  | X | E | 1736 |  |  |  | 934 |  |  | 200 | 200 | C | LND | XE80 | E | 17 | X | HT | LND | 1736 | 2011-06-20 | 2012-03-20 | E-16-04-01 |  |  | URMA |  | 2012-06-30 | 2011-09-15 | UDF_G3 |  |  |  |  |  |
| XE50173610 |  | CA17 ExtrBldgFl5 - Cable Pulling Electric Part II (over SR1708) | 30d | 2012-07-04 | 2012-08-08 | XE401736 FS-10d, EE561736 (other project), XE500C01, XE501708 SS+20d, X3E120 (other project) FF, X3E110 FF | -39.5d | 12d |  | TB26 - V - Construct-Winter partly * | Cable Pulling [6100 m]; Cable pulling [3050 h] | 122,000 | 3050,00 |  |  |  |  |  |  |  |  |  |  |  |  |  |  | XE50173610 | 3050 | 0 | 17 |  | X | E | 1736 |  |  |  | 934 |  |  | 200 | 200 | C | LND | XE50 | E | 17 | X | EL | LND | 1736 | 2011-05-20 | 2012-02-10 | E-16-01-01 |  |  | URMA |  | 2012-07-01 | 2011-10-01 | UDF_G3 | m | 6250 | 2012-02-08 | 2012-03-10 |  |
| XE50173605 |  | CA17 ExtrBldgFl5 - Cable Pulling Electric Part I (over SR1707) | 30d | 2012-07-18 | 2012-08-22 | XE501707 SS+30d, XE500C01, XE401736 FS-10d, X3E110 FF, X3E120 (other project) FF, EE561736 (other project) | -51.5d | 0d |  | TB26 - V - Construct-Winter partly * | Cable Pulling [6100 m]; Cable pulling [3050 h] | 122,000 | 3050,00 |  |  |  |  |  |  |  |  |  |  |  |  |  |  | XE50173605 | 3050 | 0 | 17 |  | X | E | 1736 |  |  |  | 934 |  |  | 200 | 200 | C | LND | XE50 | E | 17 | X | EL | LND | 1736 | 2011-05-20 | 2012-02-10 | E-16-01-01 |  |  | URMA |  | 2012-07-01 | 2011-10-01 | UDF_G3 | m | 6250 | 2012-02-03 | 2012-03-04 |  |
| XE601736 |  | CA17 ExtrBldgFl5 - Cable Termination & Testing | 60d | 2012-08-10 | 2012-10-09 | XE50173610 FS-10d, XE50173605 FS-10d, MI-22401 | -60.5d | 0d |  | TB26 - 3 - Construction Normal 7days * CA17 | Cable connecting [210 pcs]; Cable connecting [525 h] | 21,000 | 525,00 |  |  |  |  |  |  |  |  |  |  |  |  |  |  | XE601736 | 525 | 0 | 17 |  | X | E | 1736 |  |  |  | 934 |  |  | 200 | 200 | C | LND | XE60 | E | 17 | X | ET | LND | 1736 | 2011-04-20 | 2011-11-30 | E-16-02-01 |  |  | URMA |  | 2012-08-14 | 2011-12-10 | UDF_G3 |  |  |  |  |  |
|  | J | **Instrumentation** |  | 2012-03-24 | 2012-10-19 |  |  |  |  |  |  |  |  |  |  |  |  |  |  |  |  |  |  |  |  |  |  |  |  |  |  |  |  |  |  |  |  |  |  |  |  |  |  |  |  |  |  |  |  |  |  |  |  |  |  |  |  |  |  |  |  |  |  |  |  |  |  |
| XJ321736 |  | CA17 ExtrBldgFl5 - Install Junction Boxes | 40d | 2012-03-24 | 2012-05-04 | EJ321736 (other project), XC911736, P3J06ES (other project) FS+14d, XR401736 FS-45d, P3J06FS (other project) | -24.5d | 5d |  | TB26 - 3 - Construction Normal 7days * CA17 | Junction Boxes/Cabinets/Panels [25 pcs]; Install Junction Boxes/ Cabinets/ Panels [625 h] | 25,000 | 625,00 |  |  |  |  |  |  |  |  |  |  |  |  |  |  | XJ321736 | 625 | 0 | 17 |  | X | J | 1736 |  |  | Civil 100%, Equipment 100%, Piping 50% | 934 |  |  | 200 | 200 | C | LND | XJ32 | J | 17 | X | IN | LND | 1736 | 2011-09-20 | 2012-04-30 | E-17-04-10 |  |  | URMA | 2012-08-10 | 2012-08-10 | 2012-01-25 | UDF_G2 |  |  |  |  |  |
| XJ421736 |  | CA17 ExtrBldgFl5 - Install Secondary Cable Trays | 40d | 2012-04-18 | 2012-05-30 | XE401736 FS-20d, EJ46173610 (other project), XJ321736 FS-20d | -19.5d | 30d |  | TB26 - 3 - Construction Normal 7days * CA17 | Secondary cable trays [430 m]; Install secondary cable trays [1612.5 h] | 64,500 | 1612,50 |  |  |  |  |  |  |  |  |  |  |  |  |  |  | XJ421736 | 1612,5 | 0 | 17 |  | X | J | 1736 |  |  |  | 934 |  |  | 200 | 200 | C | LND | XJ42 | J | 17 | X | IN | LND | 1736 | 2011-06-10 | 2011-11-30 | E-15-01-11 |  |  | URMA |  | 2012-04-01 | 2011-09-20 | UDF_G2 | m | 673 | 2011-12-08 | 2012-02-12 | x |
| XJ441736 |  | CA17 ExtrBldgFl5 - Install Conduits to Instrm | 50d | 2012-05-10 | 2012-06-30 | XJ321736 FS-20d, XE401736, XR401736 FS-45d | -49.5d | 0d |  | TB26 - 3 - Construction Normal 7days * CA17 |  |  |  |  |  |  |  |  |  |  |  |  |  |  |  |  |  | XJ441736 | 0 | 0 | 17 |  | X | J | 1736 |  |  |  | 934 |  |  | 200 | 200 | C | LND | XJ44 | J | 17 | X | IN | LND | 1736 | 2011-09-20 | 2012-04-30 | E-17-04-10 |  |  | URMA | 2012-08-10 | 2012-08-10 | 2012-01-25 | UDF_G2 |  |  |  |  |  |
| XJ301736 |  | CA17 ExtrBldgFl5 - Install Field Instruments | 50d | 2012-05-30 | 2012-07-20 | XR801736 FS-10d, EJ361736 (other project), P3J04BS (other project), XR401736 FS-45d | -49.5d | 0d |  | TB26 - 3 - Construction Normal 7days * CA17 | Field Instruments [40 pcs]; Install field instruments [220 h] | 8,800 | 220,00 |  |  |  |  |  |  |  |  |  |  |  |  |  |  | XJ301736 | 220 | 0 | 17 |  | X | J | 1736 |  |  |  | 934 |  |  | 200 | 200 | C | LND | XJ30 | J | 17 | X | IN | LND | 1736 | 2011-09-20 | 2012-04-30 | E-17-04-10 |  |  | URMA | 2012-08-10 | 2012-08-10 | 2012-01-25 | UDF_G2 |  |  |  |  |  |
| XJ391736 |  | CA17 ExtrBldgFl5 - Install Earthing Field Eqpt | 40d | 2012-06-30 | 2012-08-09 | XJ301736 FS-20d, XJ421736, XJ441736 | -49.5d | 0d |  | TB26 - 3 - Construction Normal 7days * CA17 |  |  |  |  |  |  |  |  |  |  |  |  |  |  |  |  |  | XJ391736 | 0 | 0 | 17 |  | X | J | 1736 |  |  |  | 934 |  |  | 200 | 200 | C | LND | XJ39 | J | 17 | X | IN | LND | 1736 | 2011-09-20 | 2012-04-30 | E-17-04-10 |  |  | URMA | 2012-08-10 | 2012-08-10 | 2012-01-25 | UDF_G2 |  |  |  |  |  |
| XJ541736 |  | CA17 ExtrBldgFl5 - Pulling Singlecore Cables | 40d | 2012-06-30 | 2012-08-16 | XJ421736, XJ441736 FS-20d, XE500C01, EJ801736 (other project), XJ301736 FS-20d | -28.5d | 14d |  | TB26 - V - Construct-Winter partly * | Singlecore cables [3600 m]; Pull singlecore cables [2700 h] | 108,000 | 2700,00 |  |  |  |  |  |  |  |  |  |  |  |  |  |  | XJ541736 | 2700 | 0 | 17 |  | X | J | 1736 |  |  |  | 934 |  |  | 200 | 200 | C | LND | XJ54 | J | 17 | X | IN | LND | 1736 | 2011-09-20 | 2012-04-30 | E-17-04-10 |  |  | URMA | 2012-08-10 | 2012-08-10 | 2012-01-25 | UDF_G2 | m | 3430 | 2012-03-04 | 2012-04-13 |  |
| XJ701736 |  | CA17 ExtrBldgFl5 - Instrument Tubing | 40d | 2012-06-30 | 2012-08-09 | XJ301736 FS-20d | -49.5d | 0d |  | TB26 - 3 - Construction Normal 7days * CA17 |  |  |  |  |  |  |  |  |  |  |  |  |  |  |  |  |  | XJ701736 | 0 | 0 | 17 |  | X | J | 1736 |  |  |  | 934 |  |  | 200 | 200 | C | LND | XJ70 | J | 17 | X | IN | LND | 1736 | 2011-09-20 | 2012-04-30 | E-17-04-10 |  |  | URMA | 2012-08-10 | 2012-08-10 | 2012-01-25 | UDF_G2 |  |  |  |  |  |
| XJ521736 |  | CA17 ExtrBldgFl5 - Pulling Multicore Cables | 40d | 2012-07-04 | 2012-08-20 | XE500C01, XJ321736 SS+20d, XJ521707 SS+18d, XJ521708 SS+10d, XE401736 | -48.5d | 0d |  | TB26 - V - Construct-Winter partly * | Multicore cables [4000 m]; Pull multicore cables [2000 h] | 80,000 | 2000,00 |  |  |  |  |  |  |  |  |  |  |  |  |  |  | XJ521736 | 2000 | 0 | 17 |  | X | J | 1736 |  |  |  | 934 |  |  | 200 | 200 | C | LND | XJ52 | J | 17 | X | IN | LND | 1736 | 2011-05-20 | 2012-03-10 | E-17-01-01 |  |  | URMA |  | 2012-06-16 | 2011-11-01 | UDF_G2 | m | 2900 | 2012-02-07 | 2012-03-19 |  |
| XJ621736 |  | CA17 ExtrBldgFl5 - Termin Multicore Cables | 40d | 2012-07-27 | 2012-09-05 | XH00173605, XJ521736 FS-20d, XJ321736 | -56.5d | 4d |  | TB26 - 3 - Construction Normal 7days * CA17 | Termination Field [1413 mhr]; Termination field [1413 h] | 141,300 | 1413,00 |  |  |  |  |  |  |  |  |  |  |  |  |  |  | XJ621736 | 1413 | 0 | 17 |  | X | J | 1736 |  |  |  | 934 |  |  | 200 | 200 | C | LND | XJ62 | J | 17 | X | IN | LND | 1736 | 2011-05-20 | 2012-03-10 | E-17-01-01 |  |  | URMA |  | 2012-06-16 | 2011-11-01 | UDF_G2 |  |  |  |  |  |
| XJ641736 |  | CA17 ExtrBldgFl5 - Termin Singlecore Cables | 40d | 2012-08-09 | 2012-09-18 | XJ301736 FS-20d, XJ541736 FS-20d, XJ321736, XJ391736, XJ701736 | -49.5d | 11d |  | TB26 - 3 - Construction Normal 7days * CA17 | Termination Field [1413 mhr]; Termination field [1413 h] | 141,300 | 1413,00 |  |  |  |  |  |  |  |  |  |  |  |  |  |  | XJ641736 | 1413 | 0 | 17 |  | X | J | 1736 |  |  |  | 934 |  |  | 200 | 200 | C | LND | XJ64 | J | 17 | X | IN | LND | 1736 | 2011-09-20 | 2012-04-30 | E-17-04-10 |  |  | URMA | 2012-08-10 | 2012-08-10 | 2012-01-25 | UDF_G2 |  |  |  |  |  |
| XJ801736 |  | CA17 ExtrBldgFl5 - Inspections/ Mech. Acceptance/ Loop Checks | 40d | 2012-09-09 | 2012-10-19 | XJ641736 FS-20d, EJ801736 (other project), XJ701736, X030410030, X3J120 FF, IMS-C-000420 FF, XJ391736, XE601736 FS-30d, XJ621736 | -60.5d | 56d |  | TB26 - 3 - Construction Normal 7days * CA17 | Loop Checks [220 pcs]; Loop checks [1100 h] | 44,000 | 1100,00 |  |  |  |  |  |  |  |  |  |  |  |  |  |  | XJ801736 | 1100 | 0 | 17 |  | X | J | 1736 |  |  |  | 934 |  |  | 200 | 200 | C | LND | XJ80 | J | 17 | X | LT | LND | 1736 | 2011-06-10 | 2012-04-30 | E-17-02-01 |  |  | URMA | 2012-08-18 | 2012-08-18 | 2012-03-01 | UDF_G2 |  |  |  |  |  |

Notes:
- XE911737: UDF_PREDECESSOR: XN30, DEL XE40, DEL XE80, DEL XJ40, Civil 100%, Equipment 100%
- XE341736: UDF_PREDECESSOR: XE40, Equipment 100%, Piping 50%
- XE401736: UDF_PREDECESSOR: XN30, Piping 50%
- XE701736: UDF_PREDECESSOR: XE40, Civil 100%, HVAC ducts, Finishing works partly
- XE801736: UDF_PREDECESSOR: XR40, Piping 50% pressure tests
- XE50173610: UDF_PREDECESSOR: XE40, XE50, DEL XE34
- XE50173605: UDF_PREDECESSOR: XE40, XE50, DEL XE34
- XE601736: UDF_PREDECESSOR: XE50, Equipment 100%
- XJ321736: UDF_PREDECESSOR: Civil 100%, Equipment 100%, Piping 50%
- XJ421736: UDF_PREDECESSOR: XE40, XJ32, Equipment 100%, Piping 50%
- XJ441736: UDF_PREDECESSOR: XE40, XJ32, XJ40, Equipment 100%, Piping 50%
- XJ301736: UDF_PREDECESSOR: XR80, XR40, Equipment 100%, Piping 50%
- XJ391736: UDF_PREDECESSOR: XJ30, XJ42, XJ44, DEL XJ32, DEL XR40
- XJ541736: UDF_PREDECESSOR: XJ30, XJ42, XJ44
- XJ701736: UDF_PREDECESSOR: XJ30
- XJ521736: UDF_PREDECESSOR: XE40, XJ32, XJ52
- XJ621736: UDF_PREDECESSOR: XJ32, XJ52
- XJ641736: UDF_PREDECESSOR: XJ30, XJ32, XJ39, XJ54, XJ70
- XJ801736: UDF_PREDECESSOR: XE60, XJ39, XJ62, XJ64, XJ70

| ID | WBS | Activity | Type | Duration | Start | Finish | Predecessors | Complete | Total float | Free float | Constraint | Calendar | Resources | Cost | TB26 Ressource Budget | UDF_SELECT | UDF_SELECT UPDATE PROGRESS | UDF_SAVE ACT ID | UDF_BUDGETED LABOR UNIT | UDF_ACTUAL LABOR UNIT | Department | Constr. Area | PMT-Area | PMT-Schedule Org | PMT-Phase | PMT-Respons. | WBS Phase | WBS Discipline | WBS Type of Work | WBS Objects | Russia WBS Discipline (Russia) | Russia Construction Area | Russia WBS Phase | IMS | UPT | Russia WBS Objects | UDF_CONTRACT FINISH DATE | UDF_CONTRACT ITEM | Inquiry/Order No | UDF_CONTRACT INDICATOR | UDF_CHECK BASELINE | Zeigen/n. Zeigen | Subcontractor | Type of Work | Comments | TB26 Semantics | UDF_Weight (ton) | POSITION | WEIGHT | UDF_LEVEL | UDF_TAG No | UDF_Object No | UDF_PACKAGE | UDF_PO No | UDF_DELIVERY DATE PO | UDF_DELIVERY DATE DISPATCH PLANNED | UDF_DELIVERY DATE TO SITE PLANNED | UDF_DELIVERY DATE SITE NEED DATE | UDF_SUPPLIER | UDF_Vendor Representatives |
| --- | --- | --- | --- | --- | --- | --- | --- | --- | --- | --- | --- | --- | --- | --- | --- | --- | --- | --- | --- | --- | --- | --- | --- | --- | --- | --- | --- | --- | --- | --- | --- | --- | --- | --- | --- | --- | --- | --- | --- | --- | --- | --- | --- | --- | --- | --- | --- | --- | --- | --- | --- | --- | --- | --- | --- | --- | --- | --- | --- | --- |
|  | W | **Painting** |  |  | 2011-09-15 | 2011-11-24 |  |  |  |  |  |  |  |  |  |  |  |  |  |  |  |  |  |  |  |  |  |  |  |  |  |  |  |  |  |  |  |  |  |  |  |  |  |  |  |  |  |  |  |  |  |  |  |  |  |  |  |  |  |  |
| XW501736 |  | CA17 ExtrBldgFl5 - Surf.Protection Piping |  | 60d | 2011-09-15 | 2011-11-24 | IMS-C-000200 FF, XR201736 SS |  | 408.5d |  | start on or after 2011-09-15 |  | Piping painting [2640 h]; Piping painting [1056 sqm] | 1,921.63 | 2640,00 | OMUS-1 | 27.8. | XW501736 | 2640 | 0 | 934 | 17 | 200 | 200 | C | LND | X | W | XW50 | 1736 | W | 17 | X | PA | LND | 1736 |  |  |  |  |  |  |  |  |  |  |  |  |  |  |  |  |  |  |  |  |  |  |  |  |
|  | V | **Insulation** |  |  | 2012-05-20 | 2012-09-10 |  |  |  |  |  |  |  |  |  |  |  |  |  |  |  |  |  |  |  |  |  |  |  |  |  |  |  |  |  |  |  |  |  |  |  |  |  |  |  |  |  |  |  |  |  |  |  |  |  |  |  |  |  |  |
| XV301736 |  | CA17 ExtrBldgFl5 - Insulation Equipment |  | 100d | 2012-05-20 | 2012-08-29 | XE801736 SS+10d |  | -21.5d | 0d |  | TB26 - 3 - Construction Normal 7days * CA17 | Equipment insulation [350 sqm]; Equipment insulation [4375 h] | 1,370.27 | 4375,00 | OMUS-1 |  | XV301736 | 4375 | 0 | 934 | 17 | 200 | 200 | C | LND | X | V | XV30 | 1736 | V | 17 | X | INS | LND | 1736 | 2012-03-30 | E-13-03 |  |  |  |  |  |  |  |  |  |  |  |  |  |  |  |  |  |  |  |  |  |  |
| XV501736 |  | CA17 ExtrBldgFl5 - Insulation Piping |  | 100d | 2012-06-01 | 2012-09-10 | XV301736 FF+12d, XE801736 FF+20d, XR601736 SS+10d |  | -21.5d | 95d |  | TB26 - 3 - Construction Normal 7days * CA17 | Piping insulation [900 sqm]; Piping insulation [6750 h] | 5,475.16 | 6750,00 | OMUS-1 |  | XV501736 | 6750 | 0 | 934 | 17 | 200 | 200 | C | LND | X | V | XV50 | 1736 | V | 17 | X | INS | LND | 1736 | 2012-04-30 | E-13-01 | 2DC8990 |  |  |  |  |  |  |  |  |  |  |  |  |  |  |  |  |  |  |  |  |  |
|  | 40 | **CA17 - Extrusion Bldg 6th Floor +37,95m** |  |  | 2011-06-02 | 2012-11-11 |  |  |  |  |  |  |  |  |  |  |  |  |  |  |  |  |  |  |  |  |  |  |  |  |  |  |  |  |  |  |  |  |  |  |  |  |  |  |  |  |  |  |  |  |  |  |  |  |  |  |  |  |  |  |
|  | C | **Civil Work** |  |  | 2011-09-30 | 2012-02-20 |  |  |  |  |  |  |  |  |  |  |  |  |  |  |  |  |  |  |  |  |  |  |  |  |  |  |  |  |  |  |  |  |  |  |  |  |  |  |  |  |  |  |  |  |  |  |  |  |  |  |  |  |  |  |
| XC40174030 |  | CA17 ExtrBldgFl6 - ConcreteWorks Stairtowers North +136,85 to 140,00 |  | 26d | 2011-09-30 | 2011-10-25 | XC40173630 |  | -59d | 0d |  | TB26 - 3 - Construction Normal 7days * CA17 | Concrete works | 16,082.55 | 12300,00 |  |  | XC40174010 | 0 | 0 | 934 | 17 | 200 | 200 | C | MO04 | X | C | XC40 | 1740 | C | 17 | X | EB | LND | 1740 |  |  |  | UDF_G4 | x | C9-1 | MO11 |  |  |  |  |  |  |  |  |  |  |  |  |  |  |  |  |  |
| XC40174040 |  | CA17 ExtrBldgFl6 - ConcreteWorks Stairtowers South +136,90 to 146,30 |  | 56d | 2011-10-01 | 2011-11-26 | XC40173640 |  | 477.5d |  |  | TB26 - 3 - Construction Normal 7days * CA17 | Concrete works | 16,082.55 | 12300,00 |  |  | XC40174010 | 0 | 0 | 934 | 17 | 200 | 200 | C | MO04 | X | C | XC40 | 1740 | C | 17 | X | EB | LND | 1740 |  |  |  |  | x | C9-1 | MO11 |  |  |  |  |  |  |  |  |  |  |  |  |  |  |  |  |  |
| XC40174010 |  | CA17 ExtrBldgFl6 - ConcreteWorks Col/Wall Stairtowers abv36m North/South |  | 25d | 2012-01-17 | 2012-02-10 | X3C110 FF, IMS-C-000080 FF, EC48174010 (other project) FS+20d, XC40173610 FS-5d, XB10176014 |  | -10d | 0d |  | TB26 - 3 - Construction Normal 7days * CA17 | Concrete works [410 cbm]; Concrete works [12300 h] | 16,082.55 | 12300,00 |  |  | XC40174010 | 12300 | 0 | 934 | 17 | 200 | 200 | C | MO04 | X | C | XC40 | 1740 | C | 17 | X | EB | LND | 1740 |  |  |  |  | x | C9-1 | MO11 |  |  |  |  |  |  |  |  |  |  |  |  |  |  |  |  |  |
| XC481740 |  | CA17 ExtrBldgFl6 - Waterproofing Ceiling abv36m |  | 25d | 2012-01-27 | 2012-02-20 | XC40173620, XC40174010 FF+10d |  | -10d | 0d |  | TB26 - 3 - Construction Normal 7days * CA17 |  |  | 0 |  |  | XC481740 | 0 | 0 | 934 | 17 | 200 | 200 | C | MO04 | X | C | XC40 | 1740 | C | 17 | X | EB | LND | 1740 |  |  |  |  |  | C9-1 | MO11 |  |  |  |  |  |  |  |  |  |  |  |  |  |  |  |  |  |
| XC40174015 |  | CA17 ExtrBldgFl6 - Erection Precast Elements Stairtowers abv36m North/South |  | 10d | 2012-02-11 | 2012-02-20 | XC40173615, XC40174010, X3C110 FF, IMS-C-000080 FF |  | -4d | 0d |  | TB26 - 3 - Construction Normal 7days * CA17 | Precast Concrete Works [60 cbm]; Precast concrete works [150 h] | 6,000 | 150,00 |  |  | XC40174015 | 150 | 0 | 934 | 17 | 200 | 200 | C | MO04 | X | C | XC40 | 1740 | C | 17 | X | EB | LND | 1740 |  |  |  |  | x |  | MO11 |  |  |  |  |  |  |  |  |  |  |  |  |  |  |  |  |  |
|  | N | **Structural Steel** |  |  | 2011-06-02 | 2012-03-24 |  |  |  |  |  |  |  |  |  |  |  |  |  |  |  |  |  |  |  |  |  |  |  |  |  |  |  |  |  |  |  |  |  |  |  |  |  |  |  |  |  |  |  |  |  |  |  |  |  |  |  |  |  |  |
| XN841701 |  | CA17 ExtrBldgFl6 SK1701- KMD Assy Drawings level 136 m | milestone | 0d | 2011-06-02 A | 2011-06-02 A |  | 100% |  |  | finish on 2011-06-02 | TB26 - 3 - Construction Normal 7days * CA17 |  |  | 22t |  |  | XN841701 | 0 | 0 | 934 | 17 | 200 | 200 | C | LND | X | N | XN05 | 1740 | N | 17 | X | SS | LND | 1740 |  |  |  |  | x | KMD |  | XNK |  |  |  |  |  |  |  |  |  |  |  |  |  |  |  |  |
| XN851701 |  | CA17 ExtrBldgFl6 SK1701- Steel Deliveries level 136 m | milestone | 0d | 2011-06-10 A | 2011-06-10 A |  | 100% |  |  | finish on 2011-06-10 | TB26 - 3 - Construction Normal 7days * CA17 |  |  | 22t |  |  | XN851701 | 0 | 0 | 934 | 17 | 200 | 200 | C | LND | X | N | XN06 | 1740 | N | 17 | X | SS | LND | 1740 |  |  |  |  |  | SD |  | XNK |  |  |  |  |  |  |  |  |  |  |  |  |  |  |  |  |
| XN201740 |  | CA17 ExtrBldgFl6 SK1701 - Erec Prim Steel >36m |  | 25d | 2011-12-31 | 2012-01-31 | XN841701, XN851701 FS+10d, XN201736, XC40173620 FS-10d |  | 388.5d | 0d |  | TB26 - 3 - Construction Normal 7days * CA17 | Piperacks, Main Structures [317 t]; Piperacks, Main structures [13472.5 h] | 4,966.67 | 13472,50 | OMUS-1 |  | XN201740 | 13472,5 | 0 | 934 | 17 | 200 | 200 | C | LND | X | N | XN20 | 1740 | N | 17 | X | SS | LND | 1740 |  | E-04-17 | 2DC8990 |  |  |  | ChSK | PU10 | CA17 Heavy Lift | t |  |  |  |  |  |  |  |  |  |  |  |  |  |  |
| XN801740 |  | CA17 ExtrBldgFl6 SK1701 - Install Cladding |  | 30d | 2012-02-01 | 2012-03-02 | P3N03N (other project), XN201740, P3N02§N (other project), EN801711 (other project) |  | 388.5d |  |  | TB26 - 3 - Construction Normal 7days * CA17 | Cladding [1380 sqm]; Cladding [6900 h] | 2,266.04 | 6900,00 | OMUS-1 |  | XN801740 | 6900 | 0 | 934 | 17 | 200 | 200 | C | LND | X | N | XN80 | 1740 | N | 17 | X | SS | LND | 1740 |  |  |  |  |  |  | ChSK | XNK |  |  |  |  |  |  |  |  |  |  |  |  |  |  |  |  |
| XN301740 |  | CA17 ExtrBldgFl6 SK1701 - Install Eqpt Platforms |  | 20d | 2012-02-21 | 2012-03-13 | XC481740 |  | -10d | 0d |  | TB26 - 3 - Construction Normal 7days * CA17 | Ladders & platforms [22 t]; Ladders & platforms [2200 h] | 1,123.41 | 2200,00 | OMUS-1 |  | XN301740 | 2200 | 0 | 934 | 17 | 200 | 200 | C | LND | X | N | XN30 | 1740 | N | 17 | X | SS | LND | 1740 |  |  |  |  |  |  | ChSK | XNK |  | t |  |  |  |  |  |  |  |  |  |  |  |  |  |  |
| XN401740 |  | CA17 ExtrBldgFl6 SK1701 - Install Railings,Ladders,etc. |  | 20d | 2012-02-28 | 2012-03-19 | XC40174015, XN301740 FF+6d, EC701710 (other project) |  | -10d | 0d |  | TB26 - 3 - Construction Normal 7days * CA17 | Ladders & platforms | 155.21 | 0,00 | OMUS-1 |  | XN401740 | 0 | 0 | 934 | 17 | 200 | 200 | C | LND | X | N | XN40 | 1740 | N | 17 | X | SS | LND | 1740 |  |  |  |  |  |  | ChSK | XNK |  |  |  |  |  |  |  |  |  |  |  |  |  |  |  |  |
| XN601740 |  | CA17 ExtrBldgFl6 SK1701- Install Gratings |  | 20d | 2012-03-04 | 2012-03-24 | PN691740 (other project), XN401740 FF+5d |  | -10d | 0d |  | TB26 - 3 - Construction Normal 7days * CA17 | Grating [200 sqm]; Grating [750 h] | 8,639.94 | 750,00 | OMUS-1 |  | XN601740 | 750 | 0 | 934 | 17 | 200 | 200 | C | LND | X | N | XN60 | 1740 | N | 17 | X | SS | LND | 1740 |  |  |  |  |  |  | ChSK | XNK |  |  |  |  |  |  |  |  |  |  |  |  |  |  |  |  |
|  | H | **HVAC** |  |  |  |  |  |  |  |  |  |  |  |  |  |  |  |  |  |  |  |  |  |  |  |  |  |  |  |  |  |  |  |  |  |  |  |  |  |  |  |  |  |  |  |  |  |  |  |  |  |  |  |  |  |  |  |  |  |  |
|  | U | **Package Units** |  |  |  |  |  |  |  |  |  |  |  |  |  |  |  |  |  |  |  |  |  |  |  |  |  |  |  |  |  |  |  |  |  |  |  |  |  |  |  |  |  |  |  |  |  |  |  |  |  |  |  |  |  |  |  |  |  |  |
|  | B | **Mechanical - Stationary Equipment** |  |  | 2011-12-31 | 2012-04-11 |  |  |  |  |  |  |  |  |  |  |  |  |  |  |  |  |  |  |  |  |  |  |  |  |  |  |  |  |  |  |  |  |  |  |  |  |  |  |  |  |  |  |  |  |  |  |  |  |  |  |  |  |  |  |
| PK-21453 |  | BIG BAG LOADING STATION |  | 10d | 2011-12-31 | 2012-01-18 | P3U22S2 (other project), XB001720 FF, XB001720 SS, RF-22414, ER291700 (other project), HP-22404, XC40171820 |  | 23d | 29.88d |  |  | Static Equipment < 10 tons; Static equipment < 10t |  | 0,00 |  |  | PK-21453 | 0 | 0 |  | 17 |  |  |  |  | X | B |  | 1720 |  |  |  |  |  |  |  |  |  |  |  | EQ |  |  |  |  | 0 | a | 1100 | structure +19.20 | PK-21453 | SK1740 | PU22 VENT COLLECTION AND VACUUM SYSTEM |  |  |  |  |  |  |  |
| F-21452 |  | VACUUM SYSTEM VENT FILTER |  | 10d | 2012-02-25 | 2012-03-07 | P3U22S1 (other project), XN301730, XN201730, SE-21402 |  | -30d | 0d |  |  | Static Equipment < 10 tons [1.3 t]; Static equipment < 10t [130 h] | 5,200 | 130,00 |  |  | F-21452 | 130 | 0 |  | 17 |  |  |  |  | X | B |  | 1730 |  |  |  |  |  |  |  |  |  |  |  | EQ |  |  |  |  | 1,3 | a | 1300 | structure +26.950 | F-21452 | SK1740 | PU22 VENT COLLECTION AND VACUUM SYSTEM | 2DC9170 | 2010-10-05 | 2011-01-15 | 2011-01-27 | 2011-04-01 | Zeppelin | 026 |
| F-21451 |  | PP POWDER VENTS FILTER |  | 10d | 2012-03-14 | 2012-03-24 | XB001740 SS, F-22451 SS, XB10176014, XB001740 FF, XC481740, P3U22S1 (other project), XN301740, F-21435 SS |  | -6d | 0d |  |  | Static Equipment < 10 tons [1.1 t]; Static equipment < 10t [110 h] | 4,400 | 110,00 |  |  | F-21451 | 110 | 0 |  | 17 |  |  |  |  | X | B |  | 1740 |  |  |  |  |  |  |  |  |  |  |  | EQ |  |  |  |  | 1,1 | a | 1100 | structure +43.975 (roof) | F-21451 | SK1740 | PU22 VENT COLLECTION AND VACUUM SYSTEM |  |  |  |  |  |  |  |
| F-22451 |  | PP POWDER VENTS FILTER |  | 10d | 2012-03-14 | 2012-03-24 | XN301740, XB10176014, XB001740 SS, XB001740 FF, XC481740, F-21435 SS, P3U22S1 (other project) |  | -6d | 0d |  |  | Static Equipment < 10 tons [1.1 t]; Static equipment < 10t [110 h] | 4,400 | 110,00 |  |  | F-22451 | 110 | 0 |  | 17 |  |  |  |  | X | B |  | 1740 |  |  |  |  |  |  |  |  |  |  |  | EQ |  |  |  |  | 1,1 | a | 1100 | structure +43.975 (roof) | F-22451 | SK1740 | PU22 VENT COLLECTION AND VACUUM SYSTEM |  |  |  |  |  |  |  |
| HE-21304 |  | PURGE COLUMN NITROGEN HEATER (electrical) |  | 5d | 2012-03-14 | 2012-03-19 | XB001740 SS, XB001740 FF, XN301740, XC481740, XB10176014, C-21304, P3A06AS1 (other project) |  | 9d | 0d |  |  | Static Equipment < 10 tons [0.1 t]; Static equipment < 10t [10 h] | 400 | 10,00 |  |  | HE-21304 | 10 | 0 |  | 17 |  |  |  |  | X | B |  | 1740 |  |  |  |  |  |  |  |  |  |  |  | EQ |  |  |  |  | 0,1 | a | 1100 | structure +43.975 (roof) | HE-21304 | SK1740 | A06A NITROGEN / MINERAL OIL HEATER (ELECTRICAL) |  |  |  |  |  |  |  |
| XB001740 |  | CA17 ExtrBldgFl6 - Install Static Eqpt | level of effort | 29d | 2012-03-14 | 2012-04-11 |  |  | -1d | 0d |  | TB26 - 3 - Construction Normal 7days * CA17 |  |  | 10 | OMUS-1 |  | XB001740 | 0 | 0 | 934 | 17 | 200 | 200 | C | LND | X | B | XB00 | 1740 | B | 17 | X | EQ | LND | 1740 |  |  | 2DC8990 |  |  | C9-1 |  | PU10 |  |  |  |  |  |  |  |  |  |  |  |  |  |  |  |  |

Notes:
- XW501736: P3 Activity Log Info: Clarification Surface Protection during Prefab
- XN851701: Scope: 09.02.2011: weight: 280 ton
- XN201740: Scope: 15.02.2011 (O.Siegel): die Liefermenge fьr Level 136m / belдuft sich auf 280 t. Da die Eqpt-Platforms 25 t wiegen, bleiben fьr Prim / Steel 255 t.
- XN301740: Scope: 15.02.2011 (O.Siegel): die Liefermenge fьr Level 136m / belдuft sich auf 280 t. Da die Eqpt-Platforms 25 t wiegen, bleiben fьr Prim / Steel 255 t.

| ID | WBS | Activity | Duration | Start | Finish | Predecessors | Total float | Free float | Constraint | Calendar | Resources | Cost | TB26 Ressource Budget | UDF_Weight (ton) | POSITION | WEIGHT | UDF_LEVEL | UDF_TAG No | UDF_Object No | UDF_PACKAGE | UDF_SAVE ACT ID | UDF_BUDGETED LABOR UNIT | UDF_ACTUAL LABOR UNIT | Constr. Area | Zeigen/n. Zeigen | WBS Phase | WBS Discipline | WBS Objects | UDF_PO No | UDF_DELIVERY DATE PO | UDF_DELIVERY DATE DISPATCH PLANNED | UDF_DELIVERY DATE TO SITE PLANNED | UDF_DELIVERY DATE SITE NEED DATE | UDF_SUPPLIER | UDF_Vendor Representatives | UDF_SELECT | UDF_SELECT UPDATE PROGRESS | UDF_COMMENTS_0827 | Department | PMT-Area | PMT-Schedule Org | PMT-Phase | PMT-Respons. | WBS Type of Work | Russia WBS Discipline (Russia) | Russia Construction Area | Russia WBS Phase | IMS | UPT | Russia WBS Objects | UDF_CONTRACT START DATE | UDF_CONTRACT FINISH DATE | UDF_CONTRACT ITEM | UDF_PLANNED START | UDF_PLANNED FINISH | Subcontractor | TB26 Semantics | TB26 Material Res Values | UDF_ELECTRICAL START | UDF_ELECTRICAL FINISH | UDF_CONTRACT FINISH DATE REV1 | UDF_CONTRACT START DATE REV1 | UDF_CHECK BASELINE | UDF_INDICATOR | UDF_PENALIZED FINISH |
| --- | --- | --- | --- | --- | --- | --- | --- | --- | --- | --- | --- | --- | --- | --- | --- | --- | --- | --- | --- | --- | --- | --- | --- | --- | --- | --- | --- | --- | --- | --- | --- | --- | --- | --- | --- | --- | --- | --- | --- | --- | --- | --- | --- | --- | --- | --- | --- | --- | --- | --- | --- | --- | --- | --- | --- | --- | --- | --- | --- | --- | --- | --- | --- | --- | --- |
|  | M | **Mechanical - Rotating Equipment** |  | 2012-03-26 | 2012-04-11 |  |  |  |  |  |  |  |  |  |  |  |  |  |  |  |  |  |  |  |  |  |  |  |  |  |  |  |  |  |  |  |  |  |  |  |  |  |  |  |  |  |  |  |  |  |  |  |  |  |  |  |  |  |  |  |  |  |  |  |  |
| BL-21403A/B |  | ADDITIVE UNLOADING STATION FAN | 10d | 2012-03-26 | 2012-04-05 | XC481740, XN301740, XB001740 SS, XB001740 FF, P3U02S3 (other project), XB10176014, F-21451 | -6d | 0d |  |  | Static Equipment < 10 tons [0.8 t]; Static equipment < 10t [80 h] | 3,200 | 80,00 | 0,4 | a | 400 | concrete +39.00 (roof) | BL-21403A/B | SK1740 | PU02 ADDITIVE SYSTEM COMPONENTS (PK-21-/22401) | BL-21403A/B | 80 | 0 | 17 | EQ | X | B | 1740 |  |  |  |  |  |  |  |  |  |  |  |  |  |  |  |  |  |  |  |  |  |  |  |  |  |  |  |  |  |  |  |  |  |  |  |  |  |
| BL-22403A/B |  | ADDITIVE UNLOADING STATION FAN | 10d | 2012-03-26 | 2012-04-05 | XB10176014, XN301740, P3U02S3 (other project), F-22451, XC481740, XB001740 SS, XB001740 FF, BL-21403A/B SS | -6d | 0d |  |  | Static Equipment < 10 tons [0.8 t]; Static equipment < 10t [80 h] | 3,200 | 80,00 | 0,4 | a | 400 | concrete +39.00 (roof) | BL-22403A/B | SK1740 | PU02 ADDITIVE SYSTEM COMPONENTS (PK-21-/22401) | BL-22403A/B | 80 | 0 | 17 | EQ | X | B | 1740 |  |  |  |  |  |  |  |  |  |  |  |  |  |  |  |  |  |  |  |  |  |  |  |  |  |  |  |  |  |  |  |  |  |  |  |  |  |
| BL-21451A/B |  | PP POWDER VENT EXHAUST FAN | 10d | 2012-03-31 | 2012-04-11 | XC481740, F-21451, XB001740 SS, F-21435, XB10176014, P3U22S1 (other project), XB001740 FF | -1d | 0d |  |  | Static Equipment < 10 tons [4 t]; Static equipment < 10t [400 h] | 16,000 | 400,00 | 2 | a | 2000 | concrete +39.05 (roof) | BL-21451A/B | SK1740 | PU22 VENT COLLECTION AND VACUUM SYSTEM | BL-21451A/B | 400 | 0 | 17 | EQ | X | B | 1740 | 2DC9170 | 2010-10-05 | 2011-01-15 | 2011-01-27 | 2011-04-01 | Zeppelin | 024 |  |  |  |  |  |  |  |  |  |  |  |  |  |  |  |  |  |  |  |  |  |  |  |  |  |  |  |  |  |  |
| BL-22451 |  | PP POWDER VENT EXHAUST FAN | 10d | 2012-03-31 | 2012-04-11 | P3U22S1 (other project), XC481740, F-21451, XB10176014, XB001740 SS, XB001740 FF, F-21435 | -1d | 0d |  |  | Static Equipment < 10 tons [2 t]; Static equipment < 10t [200 h] | 8,000 | 0,00 | 2 |  |  | concrete +39.05 (roof) | BL-22451 | SK1740 | PU22 VENT COLLECTION AND VACUUM SYSTEM | BL-22451 | 200 | 0 | 17 | EQ | X | B | 1740 | 2DC9170 | 2010-10-05 | 2011-01-15 | 2011-01-27 | 2011-04-01 | Zeppelin | 024 |  |  |  |  |  |  |  |  |  |  |  |  |  |  |  |  |  |  |  |  |  |  |  |  |  |  |  |  |  |  |
|  | R | **Piping** |  | 2011-09-15 | 2012-05-24 |  |  |  |  |  |  |  |  |  |  |  |  |  |  |  |  |  |  |  |  |  |  |  |  |  |  |  |  |  |  |  |  |  |  |  |  |  |  |  |  |  |  |  |  |  |  |  |  |  |  |  |  |  |  |  |  |  |  |  |  |
| XR201740 |  | CA17 ExtrBldgFl6 - Piping Prefabrication | 90d | 2011-09-15 | 2011-12-14 | IMS-C-000180 FF, ER49174005 (other project) SS+12d, ER491740 (other project) SS+12d, XR500C00 FS+15d | 79d | 0d | start on or after 2011-09-15 | TB26 - 3 - Construction Normal 7days * CA17 | A/G piping prefabrication [1880 Fpi]; Conveying S. piping prefabrication [50 Fpi]; A/G Piping (Prefab) [7050 h]; Conveying system (Prefab) [125 h] | 15,602.22 | 7175,00 |  |  |  |  |  |  |  | XR201740 | 7175 | 0 | 17 |  | X | R | 1740 |  |  |  |  |  |  |  | OMUS-1 | 27.8. | Start mid of sept | 934 | 200 | 200 | C | LND | XR20 | R | 17 | X | PRP | LND | 1740 |  |  |  |  |  |  |  |  |  |  |  |  |  |  |  |
| XR401740 |  | CA17 ExtrBldgFl6 - Piping Installation | 70d | 2012-02-06 | 2012-04-17 | F-21451 FF+10d, HE-22304 FF+10d, BL-22451 FF, XR201740 SS+50d, F-21435 FF+10d, P3S06S (other project), BL-21451A/B FF, P3J02AS (other project), XR201740 FF+10d, F-22451 FF+10d, P3J01AS (other project), P3J02S (other project), HE-21304 FF+10d, BL-21403A/B FF+10d, BL-22403A/B FF+10d, P3J02DS (other project) | -7d | 0d |  | TB26 - 3 - Construction Normal 7days * CA17 | Control & Shut-off valves [26 pcs]; Conveying S. piping field installation [110 Fpi]; A/G Piping (Field) [14375 h]; Install Control & Shut-off Valves [136.5 h]; Conveying system (Field) [550 h]; A/G piping field installation [2300 Fpi] | 59,653.49 | 15061,50 |  |  |  |  |  |  |  | XR401740 | 15061,5 | 0 | 17 | C9-1 | X | R | 1740 |  |  |  |  |  |  |  | OMUS-1 |  |  | 934 | 200 | 200 | C | LND | XR40 | R | 17 | X | PI | LND | 1740 | 2011-02-25 | 2012-02-25 | E-06-03-07 | 2011-05-12 |  |  |  |  |  |  |  |  |  |  |  |
| XR601740 |  | CA17 ExtrBldgFl6 - Piping Pressure Tests | 40d | 2012-04-03 | 2012-05-14 | XR401740 FF+25d | -7d | 0d |  | TB26 - 3 - Construction Normal 7days * CA17 |  |  | 1241 |  |  |  |  |  |  |  | XR601740 | 0 | 0 | 17 | C9-1 | X | R | 1740 |  |  |  |  |  |  |  | OMUS-1 |  |  | 934 | 200 | 200 | C | LND | XR60 | R | 17 | X | HY | LND | 1740 | 2011-02-25 | 2012-02-25 | E-06-03-07 |  |  |  |  |  |  |  |  |  |  |  |  |
| XR801740 |  | CA17 ExtrBldgFl6 - Piping Reinstatement | 30d | 2012-04-23 | 2012-05-24 | IMS-C-000360 FF, XR601740 FF+10d | -7d | 0d |  | TB26 - 3 - Construction Normal 7days * CA17 |  |  | 620 |  |  |  |  |  |  |  | XR801740 | 0 | 0 | 17 | C9-1 | X | R | 1740 |  |  |  |  |  |  |  | OMUS-1 |  |  | 934 | 200 | 200 | C | LND | XR80 | R | 17 | X | PI | LND | 1740 | 2011-02-25 | 2012-02-25 | E-06-03-07 |  | 2012-05-11 |  |  |  |  |  |  |  |  |  |  |
|  | E | **Electrical** |  | 2012-01-12 | 2012-10-21 |  |  |  |  |  |  |  |  |  |  |  |  |  |  |  |  |  |  |  |  |  |  |  |  |  |  |  |  |  |  |  |  |  |  |  |  |  |  |  |  |  |  |  |  |  |  |  |  |  |  |  |  |  |  |  |  |  |  |  |  |
| XC911740 |  | CA17 ExtrBldgFl6 - Install Earthing&Lightn.Sys_CIVIL | 40d | 2012-01-12 | 2012-02-20 | EE901740 (other project), XC481740 FF | 181d | 292.5d |  | TB26 - 3 - Construction Normal 7days * CA17 | Grounding & Lightning [240 pcs]; Grounding & Lightning [2700 h] | 108,000 | 2700,00 |  |  |  |  |  |  |  | XC911740 | 2700 | 0 | 17 |  | X | C | 1740 |  |  |  |  |  |  |  |  |  |  | 934 | 200 | 200 | C | LND | XE91 | C | 17 | X | EA | LND | 1740 | 2011-09-20 | 2012-03-20 | E-16-07-10 |  |  | MO11 |  |  |  |  |  |  |  |  |  |
| XE401740 |  | CA17 ExtrBldgFl6 - Install Cable Trays | 20d | 2012-03-25 | 2012-04-13 | EE46174010 (other project), XR401740 SS+28d, XN301740, XN601740 | -10d | 0d |  | TB26 - 3 - Construction Normal 7days * CA17 | Cable trays/conduits [400 m]; Cable trays [1200 h] | 48,000 | 1200,00 |  |  |  |  |  |  |  | XE401740 | 1200 | 0 | 17 |  | X | E | 1740 |  |  |  |  |  |  |  |  |  |  | 934 | 200 | 200 | C | LND | XE40 | E | 17 | X | EL | LND | 1740 | 2011-06-10 | 2011-11-30 | E-15-01-11 |  |  | URMA | m | 1000 | 2011-12-28 | 2012-02-12 | 2012-04-01 | 2011-09-20 | x | UDF_G3 |  |
| XE911741 |  | CA17 ExtrBldgFl6 - Install Earthing&Lightn.Sys_E/I | 26d | 2012-04-12 | 2012-05-08 | XN301740, F-22451, BL-22451 | 51d | 162.5d |  | TB26 - 3 - Construction Normal 7days * CA17 |  |  | 265 |  |  |  |  |  |  |  | XE911741 | 0 | 0 | 17 |  | X | E | 1740 |  |  |  |  |  |  |  |  |  |  | 934 | 200 | 200 | C | LND | XE91 | E | 17 | X | EA | LND | 1740 | 2011-09-20 | 2012-03-20 | E-16-07-10 |  |  | URMA |  |  |  |  | 2012-08-15 | 2012-01-01 |  | UDF_G3 | 2012-08-15 |
| XE341740 |  | CA17 ExtrBldgFl6 - Install Local Operation Panels | 40d | 2012-04-14 | 2012-05-25 | EE46174010 (other project), XE401740, XR401740 FS-30d, BL-22451, BL-22403A/B | 307.5d |  |  | TB26 - 3 - Construction Normal 7days * CA17 | Field Panels [11 pcs]; Field panels [220 h] | 8,800 | 220,00 |  |  |  |  |  |  |  | XE341740 | 220 | 0 | 17 |  | X | E | 1740 |  |  |  |  |  |  |  |  |  |  | 934 | 200 | 200 | C | LND | XE34 | E | 17 | X | EL | LND | 1740 | 2011-09-20 | 2012-03-20 | E-16-07-10 |  |  | URMA |  |  |  |  | 2012-08-15 | 2012-01-01 |  | UDF_G3 | 2012-08-15 |
| XE701740 |  | CA17 ExtrBldgFl6 - Install Lighting &Small Power | 40d | 2012-04-14 | 2012-05-25 | P3E09S (other project), EE761700 (other project), P3E03S2 (other project) FF+20d, EE76510110 (other project) FF+20d, XE401740, XP341610 FS+50d, EE76170010 (other project) FF+20d | -10d | 87.5d |  | TB26 - 3 - Construction Normal 7days * CA17 | Lighting illuminates [120 pcs]; Lighting (iluminates) [1200 h] | 48,000 | 1200,00 |  |  |  |  |  |  |  | XE701740 | 1200 | 0 | 17 |  | X | E | 1740 |  |  |  |  |  |  |  |  |  |  | 934 | 200 | 200 | C | LND | XE70 | E | 16 | X | EL | LND | 1610 | 2011-05-10 | 2012-01-31 | E-16-03-01 |  |  | URMA |  |  |  |  | 2012-05-10 | 2011-08-15 |  | UDF_G3 |  |
| XE801740 |  | CA17 ExtrBldgFl6 - Install Heat Tracing | 40d | 2012-04-23 | 2012-06-03 | P3E19S (other project), IMS-C-000280 FF, XR401740 FS-35d, E3E1950 (other project), XR601740 FS-20d | 21d | 10d |  | TB26 - 3 - Construction Normal 7days * CA17 | Electrical Heat Tracing [900 m]; Electrical heat tracing [450 h] | 18,000 | 450,00 |  |  |  |  |  |  |  | XE801740 | 450 | 0 | 17 |  | X | E | 1740 |  |  |  |  |  |  | 005 |  |  |  | 934 | 200 | 200 | C | LND | XE80 | E | 17 | X | HT | LND | 1740 | 2011-06-20 | 2012-03-20 | E-16-04-01 |  |  | URMA |  |  |  |  | 2012-06-30 | 2011-09-15 |  | UDF_G3 |  |
| XE50174005 |  | CA17 ExtrBldgFl6 - Cable Pulling Electric Part I/II (over SR1707/08) | 40d | 2012-07-18 | 2012-09-03 | EE561740 (other project), X3E110 FF, X3E120 (other project) FF, XE501708 FS-20d, XE401740, XE501707 FS-20d, XE500C01 | -83.5d | 0d |  | TB26 - V - Construct-Winter partly * | Cable Pulling [12100 m]; Cable pulling [6050 h] | 242,000 | 6050,00 |  |  |  |  |  |  |  | XE50174005 | 6050 | 0 | 17 |  | X | E | 1740 |  |  |  |  |  |  |  |  |  |  | 934 | 200 | 200 | C | LND | XE50 | E | 17 | X | EL | LND | 1740 | 2011-05-20 | 2012-02-10 | E-16-01-01 |  |  | URMA | m | 12500 | 2012-03-05 | 2012-04-14 | 2012-07-01 | 2011-10-01 |  | UDF_G3 |  |
| XE601740 |  | CA17 ExtrBldgFl6 - Cable Termination & Testing | 60d | 2012-08-22 | 2012-10-21 | XE50174005 FS-10d, IMS-C-000260 FF, IMS-C-000390 FF, XE701740, BL-22451, HE-21304 | -97.5d | 0d |  | TB26 - 3 - Construction Normal 7days * CA17 | Cable connecting [210 pcs]; Cable connecting [525 h] | 21,000 | 525,00 |  |  |  |  |  |  |  | XE601740 | 525 | 0 | 17 |  | X | E | 1740 |  |  |  |  |  |  |  |  |  |  | 934 | 200 | 200 | C | LND | XE60 | E | 17 | X | ET | LND | 1740 | 2011-04-20 | 2011-11-30 | E-16-02-01 |  |  | URMA |  |  |  |  | 2012-08-14 | 2011-12-10 |  | UDF_G3 |  |
|  | J | **Instrumentation** |  | 2012-03-14 | 2012-11-11 |  |  |  |  |  |  |  |  |  |  |  |  |  |  |  |  |  |  |  |  |  |  |  |  |  |  |  |  |  |  |  |  |  |  |  |  |  |  |  |  |  |  |  |  |  |  |  |  |  |  |  |  |  |  |  |  |  |  |  |  |
| XJ321740 |  | CA17 ExtrBldgFl6 - Install Junction Boxes | 20d | 2012-03-14 | 2012-04-02 | P3J06FS (other project), EJ321740 (other project), P3J06ES (other project) FS+14d, XR401740 FS-35d | 33d | 11d |  | TB26 - 3 - Construction Normal 7days * CA17 | Junction Boxes/Cabinets/Panels [25 pcs]; Install Junction Boxes/ Cabinets/ Panels [625 h] | 25,000 | 625,00 |  |  |  |  |  |  |  | XJ321740 | 625 | 0 | 17 |  | X | J | 1740 |  |  |  |  |  |  |  |  |  | Civil 100%, Equipment 100%, Piping 50% | 934 | 200 | 200 | C | LND | XJ32 | J | 17 | X | IN | LND | 1740 | 2011-09-20 | 2012-04-30 | E-17-04-10 |  |  | URMA |  |  |  |  | 2012-08-10 | 2012-01-25 |  | UDF_G2 | 2012-08-10 |
| XJ421740 |  | CA17 ExtrBldgFl6 - Install Secondary Cable Trays | 20d | 2012-04-04 | 2012-04-23 | XE401740 FS-10d, EJ46174010 (other project), XJ321740 FS-10d, XR401740 FS-25d | 22d | 0d |  | TB26 - 3 - Construction Normal 7days * CA17 | Install secondary cable trays [1612.5 h]; Secondary cable trays [430 m] | 64,500 | 1612,50 |  |  |  |  |  |  |  | XJ421740 | 1612,5 | 0 | 17 |  | X | J | 1740 |  |  |  |  |  |  |  |  |  |  | 934 | 200 | 200 | C | LND | XJ42 | J | 17 | X | IN | LND | 1740 | 2011-06-10 | 2011-11-30 | E-15-01-11 |  |  | URMA | m | 673 | 2011-12-28 | 2012-02-12 | 2012-04-01 | 2011-09-20 | x | UDF_G2 |  |
| XJ441740 |  | CA17 ExtrBldgFl6 - Install Conduits to Instrm | 20d | 2012-04-14 | 2012-05-04 | XJ421740 FS-10d, XJ321740 FS-20d, XE401740, XR401740 FS-35d | 30d | 29d |  | TB26 - 3 - Construction Normal 7days * CA17 |  |  |  |  |  |  |  |  |  |  | XJ441740 | 0 | 0 | 17 |  | X | J | 1740 |  |  |  |  |  |  |  |  |  |  | 934 | 200 | 200 | C | LND | XJ44 | J | 17 | X | IN | LND | 1740 | 2011-09-20 | 2012-04-30 | E-17-04-10 |  |  | URMA |  |  |  |  | 2012-08-10 | 2012-01-25 |  | UDF_G2 | 2012-08-10 |
| XJ301740 |  | CA17 ExtrBldgFl6 - Install Field Instruments | 40d | 2012-05-15 | 2012-06-24 | P3J05S (other project), P3J04BS (other project), EJ361740 (other project), XR401740 FS-35d, XR801740 FS-10d | -7d | 0d |  | TB26 - 3 - Construction Normal 7days * CA17 | Field Instruments [40 pcs]; Install field instruments [220 h] | 8,800 | 220,00 |  |  |  |  |  |  |  | XJ301740 | 220 | 0 | 17 | C9-1 | X | J | 1740 |  |  |  |  |  |  |  |  |  |  | 934 | 200 | 200 | C | LND | XJ30 | J | 17 | X | IN | LND | 1740 | 2011-09-20 | 2012-04-30 | E-17-04-10 |  |  | URMA |  |  |  |  | 2012-08-10 | 2012-01-25 |  | UDF_G2 | 2012-08-10 |
| XJ391740 |  | CA17 ExtrBldgFl6 - Install Earthing Field Eqpt | 30d | 2012-06-04 | 2012-07-04 | XJ301740 FS-20d, XJ441740, XJ421740 | 1d | 8d |  | TB26 - 3 - Construction Normal 7days * CA17 |  |  |  |  |  |  |  |  |  |  | XJ391740 | 0 | 0 | 17 |  | X | J | 1740 |  |  |  |  |  |  |  |  |  |  | 934 | 200 | 200 | C | LND | XJ39 | J | 17 | X | IN | LND | 1740 | 2011-09-20 | 2012-04-30 | E-17-04-10 |  |  | URMA |  |  |  |  | 2012-08-10 | 2012-01-25 |  | UDF_G2 | 2012-08-10 |
| XJ541740 |  | CA17 ExtrBldgFl6 - Pulling Singlecore Cables | 40d | 2012-06-04 | 2012-07-20 | XJ441740 FS-10d, XJ421740, XE500C01, EJ801740 (other project), XJ301740 FS-20d | -6d | 0d |  | TB26 - V - Construct-Winter partly * | Singlecore cables [3600 m]; Pull singlecore cables [2700 h] | 108,000 | 2700,00 |  |  |  |  |  |  |  | XJ541740 | 2700 | 0 | 17 | C9-1 | X | J | 1740 |  |  |  |  |  |  |  |  |  |  | 934 | 200 | 200 | C | LND | XJ54 | J | 17 | X | IN | LND | 1740 | 2011-09-20 | 2012-04-30 | E-17-04-10 |  |  | URMA | m | 3430 | 2012-03-16 | 2012-04-24 | 2012-08-10 | 2012-01-25 |  | UDF_G2 | 2012-08-10 |
| XJ701740 |  | CA17 ExtrBldgFl6 - Instrument Tubing | 40d | 2012-06-04 | 2012-07-14 | XJ301740 FS-20d | -4d | 3d |  | TB26 - 3 - Construction Normal 7days * CA17 |  |  |  |  |  |  |  |  |  |  | XJ701740 | 0 | 0 | 17 |  | X | J | 1740 |  |  |  |  |  |  |  |  |  |  | 934 | 200 | 200 | C | LND | XJ70 | J | 17 | X | IN | LND | 1740 | 2011-09-20 | 2012-04-30 | E-17-04-10 |  |  | URMA |  |  |  |  | 2012-08-10 | 2012-01-25 |  | UDF_G2 | 2012-08-10 |
| XJ641740 |  | CA17 ExtrBldgFl6 - Termin Singlecore Cables | 40d | 2012-06-28 | 2012-08-06 | XJ301740 FS-20d, XJ541740 FS-20d, XJ321740, XJ391740 FS-15d, XJ701740 FS-20d | -7d | 75.5d |  | TB26 - 3 - Construction Normal 7days * CA17 | Termination Field [1413 mhr]; Termination field [1413 h] | 141,300 | 1413,00 |  |  |  |  |  |  |  | XJ641740 | 1413 | 0 | 17 | C9-1 | X | J | 1740 |  |  |  |  |  |  |  |  |  |  | 934 | 200 | 200 | C | LND | XJ64 | J | 17 | X | IN | LND | 1740 | 2011-09-20 | 2012-04-30 | E-17-04-10 |  |  | URMA |  |  |  |  | 2012-08-10 | 2012-01-25 |  | UDF_G2 | 2012-08-10 |
| XJ521740 |  | CA17 ExtrBldgFl6 - Pulling Multicore Cables | 40d | 2012-07-10 | 2012-08-25 | XJ521708 FS-15d, XE401740, XJ421740 FS-10d, XJ321740 FS-10d, XJ521707 FS-15d, XE500C01 | -53.5d | 0d |  | TB26 - V - Construct-Winter partly * | Multicore cables [3400 m]; Pull multicore cables [1700 h] | 68,000 | 1700,00 |  |  |  |  |  |  |  | XJ521740 | 1700 | 0 | 17 | C9 | X | J | 1740 |  |  |  |  |  |  |  |  |  |  | 934 | 200 | 200 | C | LND | XJ52 | J | 17 | X | IN | LND | 1740 | 2011-05-20 | 2012-03-10 | E-17-01-01 |  |  | URMA | m | 2500 | 2012-02-08 | 2012-03-30 | 2012-06-16 | 2011-11-01 |  | UDF_G2 |  |
| XJ621740 |  | CA17 ExtrBldgFl6 - Termin Multicore Cables | 40d | 2012-08-02 | 2012-09-11 | XJ521740 FS-20d, XJ321740 | -62.5d | 20d |  | TB26 - 3 - Construction Normal 7days * CA17 | Termination Field [1412 mhr]; Termination field [1412 h] | 141,200 | 1412,00 |  |  |  |  |  |  |  | XJ621740 | 1412 | 0 | 17 | C9 | X | J | 1740 |  |  |  |  |  |  |  |  |  |  | 934 | 200 | 200 | C | LND | XJ62 | J | 17 | X | IN | LND | 1740 | 2011-05-20 | 2012-03-10 | E-17-01-01 |  |  | URMA |  |  |  |  | 2012-06-16 | 2011-11-01 |  | UDF_G2 |  |
| XJ801740 |  | CA17 ExtrBldgFl6 - Inspections/ Mech. Acceptance/ Loop Checks | 40d | 2012-10-01 | 2012-11-11 | XJ391740 FS-10d, IMS-C-000420 FF, X030410030, XJ701740 FS-20d, X3J120 FF, EJ801740 (other project), XJ641740 FS-20d, X3J100 FF, XE601740 FS-20d, XJ621740 | -82.5d | 34d |  | TB26 - 3 - Construction Normal 7days * CA17 | Loop Checks [220 pcs]; Loop checks [1100 h] | 44,000 | 1100,00 |  |  |  |  |  |  |  | XJ801740 | 1100 | 0 | 17 | C9-1 | X | J | 1740 |  |  |  |  |  |  |  |  |  |  | 934 | 200 | 200 | C | LND | XJ80 | J | 17 | X | LT | LND | 1740 | 2011-06-10 | 2012-04-30 | E-17-02-01 |  |  | URMA |  |  |  |  | 2012-08-18 | 2012-03-01 |  | UDF_G2 | 2012-08-18 |

Notes:
- XE401740: UDF_PREDECESSOR: XN30, Piping 50%
- XE911741: UDF_PREDECESSOR: XN30, DEL XE40, DEL XE80, DEL XJ40, Civil 100%, Equipment 100%
- XE341740: UDF_PREDECESSOR: XE40, Equipment 100%, Piping 50%
- XE701740: UDF_PREDECESSOR: XE40, Civil 100%, HVAC ducts, Finishing works partly
- XE801740: UDF_PREDECESSOR: XR40, Piping 50% pressure tests
- XE50174005: UDF_PREDECESSOR: XE40, XE50, DEL XE34
- XE601740: UDF_PREDECESSOR: XE50, Equipment 100%
- XJ321740: UDF_PREDECESSOR: Civil 100%, Equipment 100%, Piping 50%
- XJ421740: UDF_PREDECESSOR: XE40, XJ32, Equipment 100%, Piping 50%
- XJ441740: UDF_PREDECESSOR: XE40, XJ32, XJ40, Equipment 100%, Piping 50%
- XJ301740: UDF_PREDECESSOR: XR80, XR40, Equipment 100%, Piping 50%
- XJ391740: UDF_PREDECESSOR: XJ30, XJ42, XJ44, DEL XJ32, DEL XR40
- XJ541740: UDF_PREDECESSOR: XJ30, XJ42, XJ44
- XJ701740: UDF_PREDECESSOR: XJ30
- XJ641740: UDF_PREDECESSOR: XJ30, XJ32, XJ39, XJ54, XJ70
- XJ521740: UDF_PREDECESSOR: XE40, XJ32, XJ52
- XJ621740: UDF_PREDECESSOR: XJ32, XJ52
- XJ801740: UDF_PREDECESSOR: XE60, XJ39, XJ62, XJ64, XJ70

| ID | WBS | Activity | Type | Duration | Start | Finish | Predecessors | Complete | Total float | Free float | Constraint | Calendar | Resources | Cost | TB26 Ressource Budget | UDF_SELECT | UDF_SELECT UPDATE PROGRESS | UDF_SAVE ACT ID | UDF_BUDGETED LABOR UNIT | UDF_ACTUAL LABOR UNIT | Department | Constr. Area | PMT-Area | PMT-Schedule Org | PMT-Phase | PMT-Respons. | WBS Phase | WBS Discipline | WBS Type of Work | WBS Objects | Russia WBS Discipline (Russia) | Russia Construction Area | Russia WBS Phase | IMS | UPT | Russia WBS Objects | UDF_CONTRACT FINISH DATE | UDF_CONTRACT ITEM | Comments | UDF_Text4 | Type of Work | Zeigen/n. Zeigen | UDF_CHECK BASELINE | TB26 Semantics | Subcontractor | WEIGHT | UDF_TAG No | UDF_Object No | UDF_DELIVERY DATE PO | UDF_DELIVERY DATE DISPATCH PLANNED | UDF_DELIVERY DATE TO SITE PLANNED | UDF_DELIVERY DATE SITE NEED DATE | UDF_LEVEL | UDF_Weight (ton) | POSITION | UDF_PO No | UDF_DELIVERY DATE DISPATCH ACTUAL | UDF_SHIPMENT No | UDF_SUPPLIER | UDF_CONTRACT START DATE | UDF_PENALIZED START | MTA | UDF_Vendor Representatives | UDF_CONTRACT DATE PENALIZED | UDF_PENALIZED FINISH |
| --- | --- | --- | --- | --- | --- | --- | --- | --- | --- | --- | --- | --- | --- | --- | --- | --- | --- | --- | --- | --- | --- | --- | --- | --- | --- | --- | --- | --- | --- | --- | --- | --- | --- | --- | --- | --- | --- | --- | --- | --- | --- | --- | --- | --- | --- | --- | --- | --- | --- | --- | --- | --- | --- | --- | --- | --- | --- | --- | --- | --- | --- | --- | --- | --- | --- |
|  | W | **Painting** |  |  | 2011-09-15 | 2011-11-18 |  |  |  |  |  |  |  |  |  |  |  |  |  |  |  |  |  |  |  |  |  |  |  |  |  |  |  |  |  |  |  |  |  |  |  |  |  |  |  |  |  |  |  |  |  |  |  |  |  |  |  |  |  |  |  |  |  |  |  |
| XW501740 |  | CA17 ExtrBldgFl6 - Surf.Protection Piping |  | 55d | 2011-09-15 | 2011-11-18 | XR201740 SS |  | 413.5d |  | start on or after 2011-09-15 |  | Piping painting [1056 sqm]; Piping painting [2640 h] | 1,921.63 | 2640,00 | OMUS-1 | 27.8. | XW501740 | 2640 | 0 | 934 | 17 | 200 | 200 | C | LND | X | W | XW50 | 1740 | W | 17 | X | PA | LND | 1740 |  |  |  |  |  |  |  |  |  |  |  |  |  |  |  |  |  |  |  |  |  |  |  |  |  |  |  |  |  |
|  | V | **Insulation** |  |  | 2012-04-18 | 2012-07-04 |  |  |  |  |  |  |  |  |  |  |  |  |  |  |  |  |  |  |  |  |  |  |  |  |  |  |  |  |  |  |  |  |  |  |  |  |  |  |  |  |  |  |  |  |  |  |  |  |  |  |  |  |  |  |  |  |  |  |  |
| XV301740 |  | CA17 ExtrBldgFl6 - Insulation Equipment |  | 70d | 2012-04-18 | 2012-06-29 | BL-21403A/B FS+5d, HE-21304, BL-22451 FS+5d, BL-22403A/B FS+5d, BL-21451A/B FS+5d, XE801740 FF+10d, F-22451 FS+5d, F-21451 FS+5d, HE-22304 |  | 11d | 0d |  | TB26 - 3 - Construction Normal 7days * CA17 | Equipment insulation [350 sqm]; Equipment insulation [4375 h] | 1,370.27 | 4375,00 | OMUS-1 |  | XV301740 | 4375 | 0 | 934 | 17 | 200 | 200 | C | LND | X | V | XV30 | 1740 | V | 17 | X | INS | LND | 1740 | 2012-03-30 | E-13-03 |  |  |  |  |  |  |  |  |  |  |  |  |  |  |  |  |  |  |  |  |  |  |  |  |  |  |  |
| XV501740 |  | CA17 ExtrBldgFl6 - Insulation Piping |  | 70d | 2012-04-23 | 2012-07-04 | XV301740 FF+5d, XR601740 SS+10d, XE801740 FF+20d |  | 11d | 127.5d |  | TB26 - 3 - Construction Normal 7days * CA17 | Piping insulation [900 sqm]; Piping insulation [6750 h] | 5,475.16 | 6750,00 | OMUS-1 |  | XV501740 | 6750 | 0 | 934 | 17 | 200 | 200 | C | LND | X | V | XV50 | 1740 | V | 17 | X | INS | LND | 1740 | 2012-04-30 | E-13-01 |  |  |  |  |  |  |  |  |  |  |  |  |  |  |  |  |  |  |  |  |  |  |  |  |  |  |  |
|  | 60 | **CA17 - Purge Bin Structure +94m** |  |  | 2011-06-16 | 2012-11-04 |  |  |  |  |  |  |  |  |  |  |  |  |  |  |  |  |  |  |  |  |  |  |  |  |  |  |  |  |  |  |  |  |  |  |  |  |  |  |  |  |  |  |  |  |  |  |  |  |  |  |  |  |  |  |  |  |  |  |  |
|  | 0B | **General Activities** |  |  | 2011-11-15 | 2011-11-15 |  |  |  |  |  |  |  |  |  |  |  |  |  |  |  |  |  |  |  |  |  |  |  |  |  |  |  |  |  |  |  |  |  |  |  |  |  |  |  |  |  |  |  |  |  |  |  |  |  |  |  |  |  |  |  |  |  |  |  |
| XN001760 |  | CA17 PurgeColStr - Ready f.Install PurgeBins | milestone | 0d | 2011-11-15 | 2011-11-15 | XN20176010 FF |  | -59d | 35d | finish on 2011-11-01 | TB26 - 3 - Construction Normal 7days * CA17 |  |  |  | OMUS-1 |  | XN001760 | 0 | 0 | 934 | 17 | 200 | 200 | C | LND | X | 0B | X000 | 1760 | 0 | 17 | X | EQ | LND | 1760 |  |  | CA17 Heavy Lift | CA17 - critical - CW5 | XNK | C9-1 |  |  |  |  |  |  |  |  |  |  |  |  |  |  |  |  |  |  |  |  |  |  |  |
|  | C | **Civil Work** |  |  |  |  |  |  |  |  |  |  |  |  |  |  |  |  |  |  |  |  |  |  |  |  |  |  |  |  |  |  |  |  |  |  |  |  |  |  |  |  |  |  |  |  |  |  |  |  |  |  |  |  |  |  |  |  |  |  |  |  |  |  |  |
|  | N | **Structural Steel** |  |  | 2011-06-16 | 2012-06-08 |  |  |  |  |  |  |  |  |  |  |  |  |  |  |  |  |  |  |  |  |  |  |  |  |  |  |  |  |  |  |  |  |  |  |  |  |  |  |  |  |  |  |  |  |  |  |  |  |  |  |  |  |  |  |  |  |  |  |  |
| XN701703 |  | CA17 PurgeColStr SK1703 - KMD Assy Drawings | milestone | 0d | 2011-06-16 A | 2011-06-16 A |  | 100% |  |  | finish on 2011-06-16 | TB26 - 3 - Construction Normal 7days * CA17 |  |  | 22t |  |  | XN701703 | 0 | 0 | 934 | 17 | 200 | 200 | C | LND | X | N | XN05 | 1760 | N | 17 | X | SS | LND | 1760 |  |  |  |  | XNK | KMD | x |  |  |  |  |  |  |  |  |  |  |  |  |  |  |  |  |  |  |  |  |  |  |
| XN711703 |  | CA17 PurgeColStr SK1703 - Steel Deliveries | milestone | 0d | 2011-09-16 | 2011-09-16 |  |  | -30d | 29d | finish on 2011-09-16 | TB26 - 3 - Construction Normal 7days * CA17 |  |  | 22t |  |  | XN711703 | 0 | 0 | 934 | 17 | 200 | 200 | C | LND | X | N | XN06 | 1760 | N | 17 | X | SS | LND | 1760 |  |  |  |  | XNK | SD |  |  |  |  |  |  |  |  |  |  |  |  |  |  |  |  |  |  |  |  |  |  |  |
| XN20176010 |  | CA17 PurgeColStr SK1703 - Erec Prim Steel prior H-Lift to 60.75m/76.75m |  | 20d | 2011-10-26 | 2011-11-15 | XN701703, XN711703 FS+10d, P3N02TN (other project), XC40174030 |  | -59d | 0d |  | TB26 - 3 - Construction Normal 7days * CA17 | Piperacks, Main Structures [425 t]; Piperacks, Main structures [18062.5 h] | 5,912.7 | 18062,50 | OMUS-1 / MTA |  | XN20176010 | 18062,5 | 0 | 934 | 17 | 200 | 200 | C | LND | X | N | XN20 | 1760 | N | 17 | X | SS | LND | 1760 |  | E-04-18 | CA17 Heavy Lift | CA17 - critical - CW5 | XNK | C9-1 |  | t | SM |  |  |  |  |  |  |  |  |  |  |  |  |  |  |  |  |  |  |  |  |
| XN20176020 |  | CA17 PurgeColStr SK1703 - Pre-assembly Prim Steel Frames before H-Lift |  | 20d | 2011-12-08 | 2011-12-27 | XB10176010 FF, XN20176010 FF |  | -55d | 0d |  | TB26 - 3 - Construction Normal 7days * CA17 | Piperacks, Main structures [8075 h]; Piperacks, Main Structures [190 t] | 14,190.49 | 8075,00 | OMUS-1 / MTA |  | XN20176020 | 8075 | 0 | 934 | 17 | 200 | 200 | C | LND | X | N | XN20 | 1760 | N | 17 | X | SS | LND | 1760 |  | E-04-19 |  |  | XNK |  |  | t | SM |  |  |  |  |  |  |  |  |  |  |  |  |  |  |  |  |  |  |  |  |
| XN301760 |  | CA17 PurgeColStr SK1703 - Erec / Pre-assembly Platforms |  | 25d | 2011-12-08 | 2012-01-08 | XN20176020 SS, P3N02TN (other project) |  | -55d | 0d |  | TB26 - 3 - Construction Normal 7days * CA17 |  |  |  | OMUS-1 |  | XN301760 | 0 | 0 | 934 | 17 | 200 | 200 | C | LND | X | N | XN30 | 1760 | N | 17 | X | SS | LND | 1760 |  |  |  |  | XNK |  |  |  | SM |  |  |  |  |  |  |  |  |  |  |  |  |  |  |  |  |  |  |  |  |
| XN401760 |  | CA17 PurgeColStr SK1703 - Erec / Pre-assembly Railings,Ladders,etc. |  | 25d | 2011-12-08 | 2012-01-08 | XN301760 FF |  | -55d | 0d |  | TB26 - 3 - Construction Normal 7days * CA17 | Ladders & platforms [40 t]; Ladders & platforms [4000 h] | 982.99 | 4000,00 | OMUS-1 |  | XN401760 | 4000 | 0 | 934 | 17 | 200 | 200 | C | LND | X | N | XN40 | 1760 | N | 17 | X | SS | LND | 1760 |  |  |  |  | XNK |  |  |  | SM |  |  |  |  |  |  |  |  |  |  |  |  |  |  |  |  |  |  |  |  |
| XN601760 |  | CA17 PurgeColStr SK1703 - Erec / Pre-assembly Gratings |  | 20d | 2011-12-13 | 2012-01-08 | XN401760 FF, PN691760 (other project) |  | -55d | 60d |  | TB26 - 3 - Construction Normal 7days * CA17 | Grating [1700 sqm]; Grating [6375 h] | 63,118.12 | 6375,00 | OMUS-1 |  | XN601760 | 6375 | 0 | 934 | 17 | 200 | 200 | C | LND | X | N | XN60 | 1760 | N | 17 | X | SS | LND | 1760 |  |  |  |  | XNK |  |  |  | SM |  |  |  |  |  |  |  |  |  |  |  |  |  |  |  |  |  |  |  |  |
| XN801760 |  | CA17 PurgeColStr SK1703 - Install Cladding |  | 80d | 2012-03-19 | 2012-06-08 | EN801760 (other project), P3N03N (other project), XN20176020, P3N02§N (other project), EN811760 (other project) |  | 21d | 0d | start on or after 2012-03-19 | TB26 - 3 - Construction Normal 7days * CA17 | Cladding [2510 sqm]; Cladding [12550 h] | 4,345.84 | 12550,00 | OMUS-1 |  | XN801760 | 12550 | 0 | 934 | 17 | 200 | 200 | C | LND | X | N | XN80 | 1760 | N | 17 | X | SS | LND | 1760 |  |  |  |  | XNK |  |  |  | SM |  |  |  |  |  |  |  |  |  |  |  |  |  |  |  |  |  |  |  |  |
|  | H | **HVAC** |  |  |  |  |  |  |  |  |  |  |  |  |  |  |  |  |  |  |  |  |  |  |  |  |  |  |  |  |  |  |  |  |  |  |  |  |  |  |  |  |  |  |  |  |  |  |  |  |  |  |  |  |  |  |  |  |  |  |  |  |  |  |  |
|  | U | **Package Units** |  |  |  |  |  |  |  |  |  |  |  |  |  |  |  |  |  |  |  |  |  |  |  |  |  |  |  |  |  |  |  |  |  |  |  |  |  |  |  |  |  |  |  |  |  |  |  |  |  |  |  |  |  |  |  |  |  |  |  |  |  |  |  |
|  | B | **Mechanical - Stationary Equipment** |  |  | 2011-09-26 | 2012-03-30 |  |  |  |  |  |  |  |  |  |  |  |  |  |  |  |  |  |  |  |  |  |  |  |  |  |  |  |  |  |  |  |  |  |  |  |  |  |  |  |  |  |  |  |  |  |  |  |  |  |  |  |  |  |  |  |  |  |  |  |
| HO-21401 |  | MANUAL TROLLEY HAND GEARED |  | 0d | 2011-09-26 | 2011-09-26 |  |  | 459.5d |  | start on or after 2011-09-26 |  | Static Equipment < 10 tons [0.3 t]; Static equipment < 10t [30 h] | 1,200 | 30,00 |  |  | HO-21401 | 30 | 0 |  | 17 |  |  |  |  | X | B |  | 1700 |  |  |  |  |  |  |  |  |  |  |  | EQ |  |  |  | 2200 | HO-21401 | SK1760 | 2010-10-30 | 2010-12-02 | 2011-01-06 | 2011-08-20 |  |  |  |  |  |  |  |  |  |  |  |  |  |
| HO-21402 |  | MANUAL TROLLEY HAND GEARED |  | 0d | 2011-09-26 | 2011-09-26 |  |  | 459.5d |  | start on or after 2011-09-26 |  | Static Equipment < 10 tons [0.3 t]; Static equipment < 10t [30 h] | 1,200 | 30,00 |  |  | HO-21402 | 30 | 0 |  | 17 |  |  |  |  | X | B |  | 1700 |  |  |  |  |  |  |  |  |  |  |  | EQ |  |  |  | 2200 | HO-21402 | SK1760 | 2010-10-30 | 2010-12-02 | 2011-01-06 | 2011-08-20 |  |  |  |  |  |  |  |  |  |  |  |  |  |
| HO-21403 |  | MANUAL TROLLEY HAND GEARED |  | 0d | 2011-09-26 | 2011-09-26 |  |  | 459.5d |  | start on or after 2011-09-26 |  | Static equipment < 10t [30 h]; Static Equipment < 10 tons [0.3 t] | 1,200 | 30,00 |  |  | HO-21403 | 30 | 0 |  | 17 |  |  |  |  | X | B |  | 1700 |  |  |  |  |  |  |  |  |  |  |  | EQ |  |  |  | 2200 | HO-21403 | SK1760 | 2010-10-30 | 2010-12-02 | 2011-01-06 | 2011-08-20 |  |  |  |  |  |  |  |  |  |  |  |  |  |
| HO-21404 |  | MANUAL TROLLEY HAND GEARED |  | 0d | 2011-09-26 | 2011-09-26 |  |  | 459.5d |  | start on or after 2011-09-26 |  | Static Equipment < 10 tons [0.3 t]; Static equipment < 10t [30 h] | 1,200 | 30,00 |  |  | HO-21404 | 30 | 0 |  | 17 |  |  |  |  | X | B |  | 1700 |  |  |  |  |  |  |  |  |  |  |  | EQ |  |  |  | 2200 | HO-21404 | SK1760 | 2010-10-30 | 2010-12-02 | 2011-01-06 | 2011-08-20 |  |  |  |  |  |  |  |  |  |  |  |  |  |
| HO-21405 |  | MANUAL TROLLEY HAND GEARED |  | 0d | 2011-09-26 | 2011-09-26 |  |  | 459.5d |  | start on or after 2011-09-26 |  | Static Equipment < 10 tons [0.3 t]; Static equipment < 10t [30 h] | 1,200 | 30,00 |  |  | HO-21405 | 30 | 0 |  | 17 |  |  |  |  | X | B |  | 1700 |  |  |  |  |  |  |  |  |  |  |  | EQ |  |  |  | 2200 | HO-21405 | SK1760 | 2010-10-30 | 2010-12-02 | 2011-01-06 | 2011-08-20 |  |  |  |  |  |  |  |  |  |  |  |  |  |
| HO-21406 |  | MANUAL TROLLEY HAND GEARED |  | 0d | 2011-09-26 | 2011-09-26 |  |  | 459.5d |  | start on or after 2011-09-26 |  | Static Equipment < 10 tons [0.3 t]; Static equipment < 10t [30 h] | 1,200 | 30,00 |  |  | HO-21406 | 30 | 0 |  | 17 |  |  |  |  | X | B |  | 1700 |  |  |  |  |  |  |  |  |  |  |  | EQ |  |  |  | 2200 | HO-21406 | SK1760 | 2010-10-30 | 2010-12-02 | 2011-01-06 | 2011-08-20 |  |  |  |  |  |  |  |  |  |  |  |  |  |
| HO-21407 |  | MANUAL TROLLEY HAND GEARED |  | 0d | 2011-09-26 | 2011-09-26 |  |  | 459.5d |  | start on or after 2011-09-26 |  | Static Equipment < 10 tons [0.3 t]; Static equipment < 10t [30 h] | 1,200 | 30,00 |  |  | HO-21407 | 30 | 0 |  | 17 |  |  |  |  | X | B |  | 1700 |  |  |  |  |  |  |  |  |  |  |  | EQ |  |  |  | 2200 | HO-21407 | SK1760 | 2010-10-30 | 2010-12-02 | 2011-01-06 | 2011-08-20 |  |  |  |  |  |  |  |  |  |  |  |  |  |
| HO-21408 |  | MANUAL TROLLEY HAND GEARED |  | 0d | 2011-09-26 | 2011-09-26 |  |  | 459.5d |  | start on or after 2011-09-26 |  | Static Equipment < 10 tons [0.3 t]; Static equipment < 10t [30 h] | 1,200 | 30,00 |  |  | HO-21408 | 30 | 0 |  | 17 |  |  |  |  | X | B |  | 1700 |  |  |  |  |  |  |  |  |  |  |  | EQ |  |  |  | 2200 | HO-21408 | SK1760 | 2010-10-30 | 2010-12-02 | 2011-01-06 | 2011-08-20 |  |  |  |  |  |  |  |  |  |  |  |  |  |
| MI-21302 |  | POWDER SAMPLING POT |  | 0d | 2011-09-26 | 2011-09-26 |  |  | 459.5d |  | start on or after 2011-09-26 |  | Static Equipment < 10 tons [0.18 t]; Static equipment < 10t [18 h] | 720 | 18,00 |  |  | MI-21302 | 18 | 0 |  | 17 |  |  |  |  | X | B |  | 1700 |  |  |  |  |  |  |  |  |  |  |  | EQ |  |  |  | 2200 | MI-21302 | SK1760 | 2010-10-30 | 2010-12-02 | 2011-01-06 | 2011-08-20 | structure +34.250 |  |  |  |  |  |  |  |  |  |  |  |  |
| MI-22302 |  | POWDER SAMPLING POT |  | 0d | 2011-09-26 | 2011-09-26 |  |  | 459.5d |  | start on or after 2011-09-26 |  | Static Equipment < 10 tons [0.18 t]; Static equipment < 10t [18 h] | 720 | 18,00 |  |  | MI-22302 | 18 | 0 |  | 17 |  |  |  |  | X | B |  | 1700 |  |  |  |  |  |  |  |  |  |  |  | EQ |  |  |  | 2200 | MI-22302 | SK1760 | 2010-10-30 | 2010-12-02 | 2011-01-06 | 2011-08-20 | structure +34.250 |  |  |  |  |  |  |  |  |  |  |  |  |
| XB10176005 |  | CA17 PurgeColStr - Crane Mob Purge Columns |  | 19d | 2011-12-02 | 2011-12-20 | XN20176010 FF, XB001410 |  | -94d | 0d | as late as possible | TB26 - 3 - Construction Normal 7days * CA17 |  |  |  | OMUS-1 / MTA |  | XB10176005 | 0 | 0 | 934 | 17 | 200 | 200 | C | LND | X | B | XB10 | 1760 | B | 17 | X | HL | LND | 1760 |  |  |  | CA17 - critical - CW5 | XBB |  |  |  |  |  |  |  |  |  |  |  |  |  |  |  |  |  |  |  |  |  |  |  |  |
| C-21304 |  | PURGE COLUMN |  | 6d | 2011-12-21 | 2011-12-27 | P3ALL2S (other project), XB10176010 SS |  | -52d | 12d |  |  | Static Equipment > 10 tons [61 t]; Static equipment >10t [4575 h] | 183,000 | 4575,00 |  |  | C-21304 | 4575 | 0 |  | 17 |  |  |  |  | X | B |  | 1760 |  |  |  |  |  |  |  |  |  |  |  | EQ |  |  |  | 61000 | C-21304 | SK1760 | 2010-05-04 | 2010-05-04 | 2010-09-01 | 2010-08-22 | structure +49.60 | 61 | a | 2 DC 850/ 3 | 2010-07-08 | 4000 | Wonil |  |  |  |  |  |  |
| C-22304 |  | PURGE COLUMN |  | 6d | 2011-12-21 | 2011-12-27 | XB10176010 SS, P3ALL2S (other project) |  | -56d | 8d |  |  | Static Equipment > 10 tons [61 t]; Static equipment >10t [4575 h] | 183,000 | 4575,00 |  |  | C-22304 | 4575 | 0 |  | 17 |  |  |  |  | X | B |  | 1760 |  |  |  |  |  |  |  |  |  |  |  | EQ |  |  |  | 61000 | C-22304 | SK1760 | 2010-05-04 | 2010-05-04 | 2010-09-01 | 2010-08-22 | structure +49.60 | 61 | a | 2 DC 850/ 3 | 2010-07-08 | 4000 | Wonil |  |  |  |  |  |  |
| XB10176010 |  | CA17 PurgeColStr - Heavy Lift Purge Column 1+2 (C-21304 a. C-22304) |  | 7d | 2011-12-21 | 2011-12-27 | X3B110 FF, P3ALL2S (other project), P3A08S (other project), XB001410, XB10176005, XN001760, P3B120 (other project) |  | -94d | 0d |  | TB26 - 3 - Construction Normal 7days * CA17 |  |  | 122 | OMUS-1 / MTA |  | XB10176010 | 0 | 0 | 934 | 17 | 200 | 200 | C | LND | X | B | XB10 | 1760 | B | 17 | X | HL | LND | 1760 | 2011-08-30 | E-08-01-02 | CA17 Heavy Lift | CA17 - critical - CW5 | XBB | C9-1 | x |  |  |  |  |  |  |  |  |  |  |  |  |  |  |  |  | 2011-08-20 | 2011-11-30 | MTA |  |  |  |
| XB10176012 |  | CA17 PurgeColStr - Heavy Lift pre assembled StrSteel Frames |  | 9d | 2011-12-28 | 2012-01-12 | XB10176010, P3N02TN (other project) |  | -94d | 0d |  | TB26 - 3 - Construction Normal 7days * CA17 |  |  |  | OMUS-1 / MTA |  | XB10176012 | 0 | 0 | 934 | 17 | 200 | 200 | C | LND | X | B | XB10 | 1760 | B | 17 | X | HL | LND | 1760 |  |  | CA17 Heavy Lift | CA17 - critical - CW5 | XBB | C9-1 |  |  |  |  |  |  |  |  |  |  |  |  |  |  |  |  |  |  |  |  |  |  |  |
| F-21304 |  | PURGE COLUMN VENT FILTER |  | 4d | 2012-01-13 | 2012-01-17 | C-22304, XB10176014 SS, P3A08S (other project) |  | -64d | 0d |  |  | Static Equipment < 10 tons [2.2 t]; Static equipment < 10t [220 h] | 8,800 | 220,00 |  |  | F-21304 | 220 | 0 |  | 17 |  |  |  |  | X | B |  | 1760 |  |  |  |  |  |  |  |  |  |  |  | EQ |  |  |  | 2200 | F-21304 | SK1760 | 2010-10-30 | 2010-12-02 | 2011-01-06 | 2011-08-20 | at C-21304 +61.950 | 2,2 | a | 2 DC 8560 |  |  | Zeppelin |  |  |  | 024 |  |  |
| F-22304 |  | PURGE COLUMN VENT FILTER |  | 4d | 2012-01-13 | 2012-01-17 | P3A08S (other project), XB10176014 SS |  | -40d | 0d |  |  | Static Equipment < 10 tons [2.2 t]; Static equipment < 10t [220 h] | 8,800 | 220,00 |  |  | F-22304 | 220 | 0 |  | 17 |  |  |  |  | X | B |  | 1760 |  |  |  |  |  |  |  |  |  |  |  | EQ |  |  |  | 2200 | F-22304 | SK1760 | 2010-10-30 | 2010-12-02 | 2011-01-06 | 2011-08-20 | at C-22304 +61.950 | 2,2 | a | 2 DC 8560 |  |  | Zeppelin |  |  |  | 024 |  |  |
| XB001760 |  | CA17 PurgeColStr - Install other Static Eqpt | level of effort | 63d | 2012-01-13 | 2012-03-17 |  |  | -75d | 0d |  | TB26 - 3 - Construction Normal 7days * CA17 |  |  | 36 | OMUS-1 / MTA |  | XB001760 | 0 | 0 | 934 | 17 | 200 | 200 | C | LND | X | B | XB00 | 1760 | B | 17 | X | EQ | LND | 1760 |  |  |  |  | XBB |  |  |  |  |  |  |  |  |  |  |  |  |  |  |  |  |  |  |  |  |  |  |  |  |
| XB10176014 |  | CA17 PurgeColStr - Heavy Lift Filter 1+2 |  | 4d | 2012-01-13 | 2012-01-16 | P3A08S (other project), XB10176012 |  | -94d | 0d |  | TB26 - 3 - Construction Normal 7days * CA17 |  |  |  | OMUS-1 / MTA |  | XB10176014 | 0 | 0 | 934 | 17 | 200 | 200 | C | LND | X | B | XB10 | 1760 | B | 17 | X | HL | LND | 1760 |  |  | CA17 Heavy Lift | CA17 - critical - CW5 | XBB | C9-1 |  |  |  |  |  |  |  |  |  |  |  |  |  |  |  |  |  |  | 2011-12-10 |  |  | P | 2011-12-10 |
| XB10176015 |  | CA17 PurgeColStr - Relocation of Crane |  | 6.78d | 2012-01-17 | 2012-01-23 | XB10176010, XB10176014, XB10176012 |  | 209.22d | 320.72d |  | TB26 - 3 - Construction Normal 7days * CA17 |  |  |  | OMUS-1 / MTA |  | XB10176015 | 0 | 0 | 934 | 17 | 200 | 200 | C | LND | X | B | XB10 | 1760 | B | 17 | X | HL | LND | 1760 |  |  | CA17 Heavy Lift |  | XBB |  |  |  |  |  |  |  |  |  |  |  |  |  |  |  |  |  |  |  |  |  |  |  |  |
| F-21301 |  | GAS EXPANSION BAG FILTER |  | 25d | 2012-01-18 | 2012-02-15 | P3A08S (other project), XB10176014 FF, C-21304, XB001760 FF, F-21304, XB001760 SS, XB10176010 SS |  | -64d | 0d |  |  | Static Equipment > 10 tons [18 t]; Static equipment >10t [1350 h] | 54,000 | 1350,00 |  |  | F-21301 | 1350 | 0 |  | 17 |  |  |  |  | X | B |  | 1760 |  |  |  |  |  |  |  |  |  |  |  | EQ |  |  |  | 18000 | F-21301 | SK1760 | 2010-10-30 | 2010-12-13 | 2010-02-15 | 2011-08-20 | structure +76.310 | 18 | a | 2 DC 8560 |  |  | Zeppelin |  |  |  | Zeppelin |  |  |
| F-22301 |  | GAS EXPANSION BAG FILTER |  | 25d | 2012-02-16 | 2012-03-17 | XB001760 FF, XB001760 SS, XB10176014 FF, F-22304, C-22304, P3A08S (other project), XB10176010 SS, F-21301 |  | -64d | 0d |  |  | Static Equipment > 10 tons [18 t]; Static equipment >10t [1350 h] | 54,000 | 1350,00 |  |  | F-22301 | 1350 | 0 |  | 17 |  |  |  |  | X | B |  | 1760 |  |  |  |  |  |  |  |  |  |  |  | EQ |  |  |  | 18000 | F-22301 | SK1760 | 2010-10-30 | 2010-12-13 | 2010-02-15 | 2011-08-20 | structure +76.310 | 18 | a | 2 DC 8560 |  |  | Zeppelin |  |  |  | Zeppelin |  |  |
| F-21435 |  | RERUN FEED SYSTEM FILTER |  | 15d | 2012-03-14 | 2012-03-30 | XB001740 SS, XB10176010 SS, XB10176014 FF, XN301740, XB001740 FF, P3U10S2E (other project) |  | -6d | 0d |  |  | Static Equipment < 10 tons [6.8 t]; Static equipment < 10t [680 h] | 27,200 | 680,00 |  |  | F-21435 | 680 | 0 |  | 17 |  |  |  |  | X | B |  | 1740 |  |  |  |  |  |  |  |  |  |  |  | EQ |  |  |  | 6800 | F-21435 | SK1760 |  |  |  |  | structure +43.975 | 6,8 | a |  |  |  |  |  |  |  |  |  |  |
| HE-22304 |  | PURGE COLUMN NITROGEN HEATER (electrical) |  | 5d | 2012-03-14 | 2012-03-19 | XC481740, C-22304, XN301740, XB001740 SS, XB001740 FF, XB10176014, P3A06AS1 (other project), HE-21304 SS |  | 9d | 15d |  |  | Static Equipment < 10 tons [0.1 t]; Static equipment < 10t [10 h] | 400 | 10,00 |  |  | HE-22304 | 10 | 0 |  | 17 |  |  |  |  | X | B |  | 1740 |  |  |  |  |  |  |  |  |  |  |  | EQ |  |  |  | 2200 | HE-22304 | SK1760 | 2010-10-30 | 2010-12-02 | 2011-01-06 | 2011-08-20 | structure / concrete +39.250 | 0,1 | a | 2 DC 8560 |  |  | Zeppelin |  |  |  | 024 |  |  |

Notes:
- XW501740: P3 Activity Log Info: Clarification Surface Protection during Prefab
- XN001760: Current Status: 110131 Set Primary constraint: 09.09.11 as Finish / On
- XN711703: Scope: 09.02.2011: weight: 680 ton
- XN20176010: P3 Activity Log Info: inside concrete structure
- XN20176020: P3 Activity Log Info: Clarification Preassembly
- HO-21401: UDF_PACKAGE: A12 OVERHEAD CRANES / TROLLEYS
- HO-21402: UDF_PACKAGE: A12 OVERHEAD CRANES / TROLLEYS
- HO-21403: UDF_PACKAGE: A12 OVERHEAD CRANES / TROLLEYS
- HO-21404: UDF_PACKAGE: A12 OVERHEAD CRANES / TROLLEYS
- HO-21405: UDF_PACKAGE: A12 OVERHEAD CRANES / TROLLEYS
- HO-21406: UDF_PACKAGE: A12 OVERHEAD CRANES / TROLLEYS
- HO-21407: UDF_PACKAGE: A12 OVERHEAD CRANES / TROLLEYS
- HO-21408: UDF_PACKAGE: A12 OVERHEAD CRANES / TROLLEYS
- MI-21302: UDF_PACKAGE: A01 PRESSURE EQUIPMENT
- MI-22302: UDF_PACKAGE: A01 PRESSURE EQUIPMENT
- C-21304: UDF_PACKAGE: ALL2 PURGE COLUMNS / REACTOR OVERHEAD SEPARATORS (C-21-/22304, V-21-/22304)
- C-22304: UDF_PACKAGE: ALL2 PURGE COLUMNS / REACTOR OVERHEAD SEPARATORS (C-21-/22304, V-21-/22304)
- F-21304: UDF_PACKAGE: A08 PURGE COLUMNS VENT / GAS EXP. BAG FILTER (F-21-/22301/4)
- F-22304: UDF_PACKAGE: A08 PURGE COLUMNS VENT / GAS EXP. BAG FILTER (F-21-/22301/4)
- F-21301: UDF_PACKAGE: A08 PURGE COLUMNS VENT / GAS EXP. BAG FILTER (F-21-/22301/4)
- F-22301: UDF_PACKAGE: A08 PURGE COLUMNS VENT / GAS EXP. BAG FILTER (F-21-/22301/4)
- F-21435: UDF_PACKAGE: PU10 CONVEYING SYSTEM (PK-21501) ZEPPELIN
- HE-22304: UDF_PACKAGE: A08 PURGE COLUMNS VENT / GAS EXP. BAG FILTER (F-21-/22301/4)

| ID | WBS | Activity | Type | Duration | Start | Finish | Predecessors | Total float | Free float | Constraint | Calendar | Resources | Cost | TB26 Ressource Budget | UDF_Weight (ton) | POSITION | WEIGHT | UDF_LEVEL | UDF_PO No | UDF_TAG No | UDF_Object No | UDF_DELIVERY DATE PO | UDF_DELIVERY DATE DISPATCH PLANNED | UDF_DELIVERY DATE TO SITE PLANNED | UDF_DELIVERY DATE SITE NEED DATE | UDF_PACKAGE | UDF_SUPPLIER | UDF_Vendor Representatives | UDF_SAVE ACT ID | UDF_BUDGETED LABOR UNIT | UDF_ACTUAL LABOR UNIT | Constr. Area | Zeigen/n. Zeigen | WBS Phase | WBS Discipline | WBS Objects | UDF_SELECT | UDF_CONTRACT START DATE | UDF_CONTRACT FINISH DATE | UDF_CONTRACT ITEM | Department | Type of Work | PMT-Area | PMT-Schedule Org | PMT-Phase | PMT-Respons. | WBS Type of Work | Russia WBS Discipline (Russia) | Russia Construction Area | Russia WBS Phase | IMS | UPT | Russia WBS Objects | UDF_SELECT UPDATE PROGRESS | UDF_COMMENTS_0827 | UDF_PLANNED START | UDF_CONTRACT DATE PENALIZED | UDF_PLANNED FINISH | UDF_PENALIZED START | UDF_PENALIZED FINISH | Subcontractor | TB26 Semantics | TB26 Material Res Values | UDF_ELECTRICAL START | UDF_ELECTRICAL FINISH | UDF_CONTRACT FINISH DATE REV1 | UDF_CONTRACT START DATE REV1 | UDF_CHECK BASELINE | UDF_PREDECESSOR | UDF_INDICATOR |
| --- | --- | --- | --- | --- | --- | --- | --- | --- | --- | --- | --- | --- | --- | --- | --- | --- | --- | --- | --- | --- | --- | --- | --- | --- | --- | --- | --- | --- | --- | --- | --- | --- | --- | --- | --- | --- | --- | --- | --- | --- | --- | --- | --- | --- | --- | --- | --- | --- | --- | --- | --- | --- | --- | --- | --- | --- | --- | --- | --- | --- | --- | --- | --- | --- | --- | --- | --- | --- | --- | --- |
|  | M | **Mechanical - Rotating Equipment** |  |  | 2012-01-13 | 2012-02-16 |  |  |  |  |  |  |  |  |  |  |  |  |  |  |  |  |  |  |  |  |  |  |  |  |  |  |  |  |  |  |  |  |  |  |  |  |  |  |  |  |  |  |  |  |  |  |  |  |  |  |  |  |  |  |  |  |  |  |  |  |  |  |  |  |
| RF-21301 |  | EXPANSION BAG FILTER OUTLET ROTARY FEEDER |  | 30d | 2012-01-13 | 2012-02-16 | XM001760 FF, XB10176010 SS, XM001760 SS, XB001760 FF, P3M12S2 (other project), XB001760 SS, F-21304 SS | -40d | 24d |  |  | Rotating Equipment (w/o lube oil unit) [11.84 t]; Rotating equipment (w/o lube oil unit) [1184.3 h] | 41,450.5 | 1184,30 | 1,9 | a | 1900 | structure +63.950 | 2 DC 8940/ 4 | RF-21301 | SK1760 | 2010-10-20 | 2011-01-15 | 2011-01-30 | 2011-04-10 | M12 ROTARY FEEDER (RF-21-/22301/4) | Zeppelin | 030 | RF-21301 | 1184,3 | 0 | 17 | EQ | X | M | 1760 |  |  |  |  |  |  |  |  |  |  |  |  |  |  |  |  |  |  |  |  |  |  |  |  |  |  |  |  |  |  |  |  |  |  |
| RF-22301 |  | EXPANSION BAG FILTER OUTLET ROTARY FEEDER |  | 30d | 2012-01-13 | 2012-02-16 | XB001760 FF, XM001760 FF, XB10176010 SS, XM001760 SS, P3M12S2 (other project), XB001760 SS, F-22304 SS | -40d | 24d |  |  | Rotating Equipment (w/o lube oil unit) [11.26 t]; Rotating equipment (w/o lube oil unit) [1126.3 h] | 39,410 | 1126,30 | 1,9 | a | 1900 | structure +63.950 | 2 DC 8940/ 4 | RF-22301 | SK1760 | 2010-10-20 | 2011-01-15 | 2011-01-30 | 2011-04-10 | M12 ROTARY FEEDER (RF-21-/22301/4) | Zeppelin | 030 | RF-22301 | 1126,3 | 0 | 17 | EQ | X | M | 1760 |  |  |  |  |  |  |  |  |  |  |  |  |  |  |  |  |  |  |  |  |  |  |  |  |  |  |  |  |  |  |  |  |  |  |
| XM001760 |  | CA17 PurgeColStr - Install other Rot Eqpt | level of effort | 35d | 2012-01-13 | 2012-02-16 |  | -47d | 0d |  | TB26 - 3 - Construction Normal 7days * CA17 |  |  | 2 |  |  |  |  |  |  |  |  |  |  |  |  |  |  | XM001760 | 0 | 0 | 17 |  | X | M | 1760 | OMUS-1 | 2011-09-01 | 2011-09-10 | E-08-01-17 | 934 | XBB | 200 | 200 | C | LND | XM00 | M | 17 | X | EQ | LND | 1760 |  |  |  |  |  |  |  |  |  |  |  |  |  |  |  |  |  |
|  | R | **Piping** |  |  | 2011-09-15 | 2012-06-19 |  |  |  |  |  |  |  |  |  |  |  |  |  |  |  |  |  |  |  |  |  |  |  |  |  |  |  |  |  |  |  |  |  |  |  |  |  |  |  |  |  |  |  |  |  |  |  |  |  |  |  |  |  |  |  |  |  |  |  |  |  |  |  |  |
| XR201760 |  | CA17 PurgeColStr - Piping Prefabrication |  | 90d | 2011-09-15 | 2011-12-14 | ER49176005 (other project) SS+12d, ER491760 (other project) SS+12d, IMS-E-000030 (other project) FF+55d, XR500C00 FS+15d | 23d | 0d | start on or after 2011-09-15 | TB26 - 3 - Construction Normal 7days * CA17 | A/G piping prefabrication [3750 Fpi]; A/G Piping (Prefab) [14062.5 h] | 10,602.22 | 14062,50 |  |  |  |  |  |  |  |  |  |  |  |  |  |  | XR201760 | 14062,5 | 0 | 17 |  | X | R | 1760 | OMUS-1 |  |  |  | 934 |  | 200 | 200 | C | LND | XR20 | R | 17 | X | PRP | LND | 1760 | 27.8. | Start mid of sept |  |  |  |  |  |  |  |  |  |  |  |  |  |  |  |
| XR401760 |  | CA17 PurgeColStr - Piping Installation |  | 60d | 2012-03-11 | 2012-05-14 | XR401303 FS+10d, P3S06S (other project), C-21304 FF+20d, XR201760 SS+30d, P3J02BS (other project), P3J02S (other project), C-22304 FF+20d, F-21304 FF+20d, F-22301 FF+20d, P3J01AS (other project), XN601760 SS+20d, F-21301 FF+20d, XR201760 FF+30d, P3J02CS (other project), F-22304 FF+20d, IMS-C-000190 FF, P3J02AS (other project), P3S02S (other project), XB30176020, P3J01S (other project), P3S01S (other project) | -71d | 0d |  | TB26 - 3 - Construct-winter 7days * | Control & Shut-off valves [19 pcs]; A/G piping field installation [4590 Fpi]; A/G Piping (Field) [28687.5 h]; Install Control & Shut-off Valves [99.75 h]; Conveying S. piping field installation [150 Fpi]; Conveying system (Field) [750 h] | 64,183.49 | 29537,25 |  |  |  |  |  |  |  |  |  |  |  |  |  |  | XR401760 | 29537,25 | 0 | 17 |  | X | R | 1760 | OMUS-1 | 2011-02-25 | 2012-02-25 | E-06-03-07 | 934 |  | 200 | 200 | C | LND | XR40 | R | 17 | X | PI | LND | 1760 |  |  | 2011-05-12 |  |  |  |  |  |  |  |  |  |  |  |  |  |  |
| XR601760 |  | CA17 PurgeColStr - Piping Pressure Tests |  | 40d | 2012-04-28 | 2012-06-08 | XR401760 FS-15d, IMS-C-000360 FF | -64d | 0d |  | TB26 - 3 - Construct-winter 7days * |  |  | 838 |  |  |  |  |  |  |  |  |  |  |  |  |  |  | XR601760 | 0 | 0 | 17 |  | X | R | 1760 | OMUS-1 | 2011-02-25 | 2012-02-25 | E-06-03-07 | 934 |  | 200 | 200 | C | LND | XR60 | R | 17 | X | HY | LND | 1760 |  |  |  |  |  |  |  |  |  |  |  |  |  |  |  |  |  |
| XR801760 |  | CA17 PurgeColStr - Piping Reinstatement |  | 20d | 2012-05-30 | 2012-06-19 | IMS-C-000360 FF, XR601760 FF+10d | -64d | 0d |  | TB26 - 3 - Construct-winter 7days * |  |  | 419 |  |  |  |  |  |  |  |  |  |  |  |  |  |  | XR801760 | 0 | 0 | 17 |  | X | R | 1760 | OMUS-1 | 2011-02-25 | 2012-02-25 | E-06-03-07 | 934 |  | 200 | 200 | C | LND | XR80 | R | 17 | X | PI | LND | 1760 |  |  |  | P | 2012-05-11 | 2012-05-12 | 2012-05-12 |  |  |  |  |  |  |  |  |  |  |
|  | E | **Electrical** |  |  | 2012-03-19 | 2012-09-09 |  |  |  |  |  |  |  |  |  |  |  |  |  |  |  |  |  |  |  |  |  |  |  |  |  |  |  |  |  |  |  |  |  |  |  |  |  |  |  |  |  |  |  |  |  |  |  |  |  |  |  |  |  |  |  |  |  |  |  |  |  |  |  |  |
| XC911760 |  | CA17 PurgeColStr - Install Earthing&Lightn.Sys_E/I |  | 30d | 2012-03-19 | 2012-04-19 | XN20176020, XN801760 SS, EE901740 (other project) | 124d | 235.5d |  | TB26 - 3 - Construct-winter 7days * | Grounding & Lightning [140 pcs]; Grounding & Lightning [1575 h] | 63,000 | 1575,00 |  |  |  |  |  |  |  |  |  |  |  |  |  |  | XC911760 | 1575 | 0 | 17 |  | X | C | 1760 |  |  |  |  | 934 |  | 200 | 200 | C | LND | XE91 | E | 17 | X | EA | LND | 1740 |  |  |  |  |  |  |  | MO11 |  |  |  |  |  |  |  |  |  |
| XE401760 |  | CA17 PurgeColStr - Install Cable Trays |  | 50d | 2012-04-13 | 2012-06-03 | XR401760 FS-30d, XN601760, EE46176010 (other project) | -71d | 0d |  | TB26 - 3 - Construct-winter 7days * | Cable trays [960 h]; Cable trays/conduits [320 m] | 38,400 | 960,00 |  |  |  |  |  |  |  |  |  |  |  |  |  |  | XE401760 | 960 | 0 | 17 |  | X | E | 1760 |  | 2011-06-10 | 2011-11-30 | E-15-01-11 | 934 |  | 200 | 200 | C | LND | XE40 | E | 17 | X | EL | LND | 1760 |  |  |  |  |  |  |  | URMA | m | 800 | 2011-10-29 | 2011-12-11 | 2012-04-01 | 2011-09-20 | x | XN30, Piping 50% | UDF_G3 |
| XE701760 |  | CA17 PurgeColStr - Install Lighting &Small Power |  | 30d | 2012-05-15 | 2012-06-14 | XP341610 FS+50d, XE401760 FS-20d, P3E09S (other project), EE761700 (other project), EE76170010 (other project) FF+20d, EE76510110 (other project) FF+20d, P3E03S2 (other project) FF+20d, XN601760, XN301760 | 16d | 127.5d |  | TB26 - 3 - Construct-winter 7days * | Lighting illuminates [120 pcs]; Lighting (iluminates) [1200 h] | 48,000 | 1200,00 |  |  |  |  |  |  |  |  |  |  |  |  |  |  | XE701760 | 1200 | 0 | 17 |  | X | E | 1760 |  | 2011-05-10 | 2012-01-31 | E-16-03-01 | 934 |  | 200 | 200 | C | LND | XE70 | E | 16 | X | EL | LND | 1610 |  |  |  |  |  |  |  | URMA |  |  |  |  | 2012-05-10 | 2011-08-15 |  | XE40, Civil 100%, HVAC ducts, Finishing works partly | UDF_G3 |
| XE341760 |  | CA17 PurgeColStr - Install Local Operation Panels |  | 30d | 2012-05-25 | 2012-06-24 | EE46176010 (other project), XE401760 FS-10d, F-22301, XR401760 FS-30d | 279.5d |  |  | TB26 - 3 - Construct-winter 7days * | Field Panels [11 pcs]; Field panels [220 h] | 8,800 | 220,00 |  |  |  |  |  |  |  |  |  |  |  |  |  |  | XE341760 | 220 | 0 | 17 |  | X | E | 1760 |  |  |  |  | 934 |  | 200 | 200 | C | LND | XE34 | E | 17 | X | EL | LND | 1740 |  |  |  |  |  |  |  | URMA |  |  |  |  |  |  |  | XE40, Equipment 100%, Piping 50% | UDF_G3 |
| XE801760 |  | CA17 PurgeColStr - Install Heat Tracing |  | 40d | 2012-05-30 | 2012-07-09 | XW501760 FF+20d, C-22304 FF+30d, C-21304 FF+30d, F-22301 FF+3d, RF-21301 FF+30d, F-22304 FF+30d, F-21301 FF+30d, F-21304 FF+30d, XR601760 FS-10d, E3E1950 (other project), IMS-C-000280 FF, RF-22301 FF+30d, IMS-C-000260 FF | -14d | 0d |  | TB26 - 3 - Construction Normal 7days * CA17 | Electrical Heat Tracing [900 m]; Electrical heat tracing [450 h] | 18,000 | 450,00 |  |  |  |  |  |  |  |  |  |  |  |  |  | 005 | XE801760 | 450 | 0 | 17 |  | X | E | 1760 |  | 2011-06-20 | 2012-03-20 | E-16-04-01 | 934 |  | 200 | 200 | C | LND | XE80 | E | 17 | X | HT | LND | 1760 |  |  |  |  |  |  |  | URMA |  |  |  |  | 2012-06-30 | 2011-09-15 |  | XR40, Piping 50% pressure tests | UDF_G3 |
| XE50176010 |  | CA17 PurgeColStr - Cable Pulling Electric Part II (over SR1708) |  | 30d | 2012-06-25 | 2012-07-30 | XE501708 FS-30d, EE561760 (other project), XE401760 FS-20d, XE500C01 | -53.5d | 20d |  | TB26 - V - Construct-Winter partly * | Cable Pulling [6100 m]; Cable pulling [3050 h] | 122,000 | 3050,00 |  |  |  |  |  |  |  |  |  |  |  |  |  |  | XE50176010 | 3050 | 0 | 17 |  | X | E | 1760 |  | 2011-05-20 | 2012-02-10 | E-16-01-01 | 934 |  | 200 | 200 | C | LND | XE50 | E | 17 | X | EL | LND | 1760 |  |  |  |  |  |  |  | URMA | m | 6250 | 2012-03-05 | 2012-04-08 | 2012-07-01 | 2011-10-01 |  | XE40, XE50, DEL XE34 | UDF_G3 |
| XE50176005 |  | CA17 PurgeColStr - Cable Pulling Electric Part I (over SR1707) |  | 30d | 2012-07-18 | 2012-08-22 | XE500C01, EE561760 (other project), XE501707 FS-20d, XE401760 FS-20d | -73.5d | 0d |  | TB26 - V - Construct-Winter partly * | Cable Pulling [6100 m]; Cable pulling [3050 h] | 122,000 | 3050,00 |  |  |  |  |  |  |  |  |  |  |  |  |  |  | XE50176005 | 3050 | 0 | 17 |  | X | E | 1760 |  | 2011-05-20 | 2012-02-10 | E-16-01-01 | 934 |  | 200 | 200 | C | LND | XE50 | E | 17 | X | EL | LND | 1760 |  |  |  |  |  |  |  | URMA | m | 6250 | 2011-11-24 | 2012-01-23 | 2012-07-01 | 2011-10-01 |  | XE40, XE50, DEL XE34 | UDF_G3 |
| XE601760 |  | CA17 PurgeColStr - Cable Termination & Testing |  | 30d | 2012-08-10 | 2012-09-09 | XE50176005 FS-10d, XE50176010 FS-10d, RF-21301, F-22301 | -85.5d | 26d |  | TB26 - 3 - Construction Normal 7days * CA17 | Cable connecting [160 pcs]; Cable connecting [400 h] | 16,000 | 400,00 |  |  |  |  |  |  |  |  |  |  |  |  |  |  | XE601760 | 400 | 0 | 17 |  | X | E | 1760 |  | 2011-04-20 | 2011-11-30 | E-16-02-01 | 934 |  | 200 | 200 | C | LND | XE60 | E | 17 | X | ET | LND | 1760 |  |  |  |  |  |  |  | URMA |  |  |  |  | 2012-08-14 | 2011-12-10 |  | XE50, Equipment 100% | UDF_G3 |
|  | J | **Instrumentation** |  |  | 2012-04-13 | 2012-11-04 |  |  |  |  |  |  |  |  |  |  |  |  |  |  |  |  |  |  |  |  |  |  |  |  |  |  |  |  |  |  |  |  |  |  |  |  |  |  |  |  |  |  |  |  |  |  |  |  |  |  |  |  |  |  |  |  |  |  |  |  |  |  |  |  |
| XJ321760 |  | CA17 PurgeColStr - Install Junction Boxes |  | 20d | 2012-04-13 | 2012-05-03 | EJ321760 (other project), XR401760 FS-30d, RF-22301 | -31d | 10d |  | TB26 - 3 - Construct-winter 7days * | Junction Boxes/Cabinets/Panels [25 pcs]; Install Junction Boxes/ Cabinets/ Panels [625 h] | 25,000 | 625,00 |  |  |  |  |  |  |  |  |  |  |  |  |  |  | XJ321760 | 625 | 0 | 17 |  | X | J | 1760 |  |  |  |  | 934 |  | 200 | 200 | C | LND | XJ32 | J | 17 | X | IN | LND | 1760 |  | Civil 100%, Equipment 100%, Piping 50% |  |  |  |  |  | URMA |  |  |  |  |  |  |  | Civil 100%, Equipment 100%, Piping 50% | UDF_G2 |
| XJ421760 |  | CA17 PurgeColStr - Install Secondary Cable Trays |  | 20d | 2012-05-15 | 2012-06-03 | EJ46170710 (other project), XJ321760, EJ461760 (other project), XE401760 FS-20d, XR401760 FS-30d | -34d | 30d |  | TB26 - 3 - Construct-winter 7days * | Secondary cable trays [430 m]; Install secondary cable trays [1612.5 h] | 64,500 | 1612,50 |  |  |  |  |  |  |  |  |  |  |  |  |  |  | XJ421760 | 1612,5 | 0 | 17 |  | X | J | 1760 |  | 2011-06-10 | 2011-11-30 | E-15-01-11 | 934 |  | 200 | 200 | C | LND | XJ42 | J | 17 | X | IN | LND | 1760 |  |  |  |  |  |  |  | URMA | m | 673 | 2011-10-29 | 2011-12-11 | 2012-04-01 | 2011-09-20 | x | XE40, XJ32, Equipment 100%, Piping 50% | UDF_G2 |
| XJ301760 |  | CA17 PurgeColStr - Install Field Instruments |  | 50d | 2012-06-09 | 2012-07-29 | P3J13AS (other project), P3J14AS (other project), XR801760 FS-10d, P3J13BS (other project), P3J12DS (other project), P3J13S (other project), P3J07AS (other project), P3J13CS (other project), P3J03S3 (other project), EJ361760 (other project), P3J14BS (other project), P3J04BS (other project), P3J04ES (other project), P3J14S (other project), P3J12BS (other project), XR401760 FS-30d | -64d | 0d |  | TB26 - 3 - Construct-winter 7days * | Field Instruments [40 pcs]; Install field instruments [220 h] | 8,800 | 220,00 |  |  |  |  |  |  |  |  |  |  |  |  |  |  | XJ301760 | 220 | 0 | 17 |  | X | J | 1760 |  |  |  |  | 934 |  | 200 | 200 | C | LND | XJ30 | J | 17 | X | IN | LND | 1760 |  |  |  |  |  |  |  | URMA |  |  |  |  |  |  |  | XR80, XR40, Equipment 100%, Piping 50% | UDF_G2 |
| XJ391760 |  | CA17 PurgeColStr - Install Earthing Field Eqpt |  | 30d | 2012-07-05 | 2012-08-03 | XJ301760 FF+5d, XJ421760 | -64d | 47.5d |  | TB26 - 3 - Construct-winter 7days * |  |  |  |  |  |  |  |  |  |  |  |  |  |  |  |  |  | XJ391760 | 0 | 0 | 17 |  | X | J | 1760 |  |  |  |  | 934 |  | 200 | 200 | C | LND | XJ39 | J | 17 | X | IN | LND | 1760 |  |  |  |  |  |  |  | URMA |  |  |  |  |  |  |  | XJ30, XJ42, XJ44, DEL XJ32, DEL XR40 | UDF_G2 |
| XJ701760 |  | CA17 PurgeColStr - Instrument Tubing |  | 20d | 2012-07-10 | 2012-07-29 | XJ301760 FS-20d | -49d | 62.5d |  | TB26 - 3 - Construct-winter 7days * |  |  |  |  |  |  |  |  |  |  |  |  |  |  |  |  |  | XJ701760 | 0 | 0 | 17 |  | X | J | 1760 |  |  |  |  | 934 |  | 200 | 200 | C | LND | XJ70 | J | 17 | X | IN | LND | 1760 |  |  |  |  |  |  |  | URMA |  |  |  |  |  |  |  | XJ30 | UDF_G2 |
| XJ521760 |  | CA17 PurgeColStr - Pulling Multicore Cables |  | 40d | 2012-07-16 | 2012-08-31 | XJ521708 FS-10d, P3J17S1 (other project), XJ521707 FS-10d, XJ321760 FS-10d, XE500C01, XE401760 | -95.5d | 0d |  | TB26 - V - Construct-Winter partly * | Multicore cables [3400 m]; Pull multicore cables [1700 h] | 68,000 | 1700,00 |  |  |  |  |  |  |  |  |  |  |  |  |  |  | XJ521760 | 1700 | 0 | 17 |  | X | J | 1760 |  | 2011-05-20 | 2012-03-10 | E-17-01-01 | 934 |  | 200 | 200 | C | LND | XJ52 | J | 17 | X | IN | LND | 1760 |  |  |  |  |  |  |  | URMA | m | 2500 | 2012-02-19 | 2012-04-07 | 2012-06-16 | 2011-11-01 |  | XE40, XJ32, XJ52 | UDF_G2 |
| XJ621760 |  | CA17 PurgeColStr - Termin Multicore Cables |  | 40d | 2012-08-08 | 2012-09-17 | XJ521760 FS-20d, XJ321760 | -111.5d | 0d |  | TB26 - 3 - Construct-winter 7days * | Termination Field [1412 mhr]; Termination field [1412 h] | 141,200 | 1412,00 |  |  |  |  |  |  |  |  |  |  |  |  |  |  | XJ621760 | 1412 | 0 | 17 |  | X | J | 1760 |  | 2011-05-20 | 2012-03-10 | E-17-01-01 | 934 |  | 200 | 200 | C | LND | XJ62 | J | 17 | X | IN | LND | 1760 |  |  |  |  |  |  |  | URMA |  |  |  |  | 2012-06-16 | 2011-11-01 |  | XJ32, XJ52 | UDF_G2 |
| XJ541760 |  | CA17 PurgeColStr - Pulling Singlecore Cables |  | 30d | 2012-08-28 | 2012-10-02 | XJ421760, XE500C01, EJ801760 (other project), XJ301760 FS-25d, XJ621760 FS-20d | -95.5d | 0d |  | TB26 - V - Construct-Winter partly * | Singlecore cables [3600 m]; Pull singlecore cables [2700 h] | 108,000 | 2700,00 |  |  |  |  |  |  |  |  |  |  |  |  |  |  | XJ541760 | 2700 | 0 | 17 |  | X | J | 1760 |  |  |  |  | 934 |  | 200 | 200 | C | LND | XJ54 | J | 17 | X | IN | LND | 1760 |  |  |  |  |  |  |  | URMA | m | 3430 | 2012-03-16 | 2012-04-14 |  |  |  | XJ30, XJ42, XJ44 | UDF_G2 |
| XJ641760 |  | CA17 PurgeColStr - Termin Singlecore Cables |  | 30d | 2012-09-20 | 2012-10-20 | XJ541760 FS-10d, XJ301760, XJ321760, XJ391760, XJ701760 FS-10d | -111.5d | 0d |  | TB26 - 3 - Construction Normal 7days * CA17 | Termination Field [1412 mhr]; Termination field [1412 h] | 141,200 | 1412,00 |  |  |  |  |  |  |  |  |  |  |  |  |  |  | XJ641760 | 1412 | 0 | 17 |  | X | J | 1760 |  |  |  |  | 934 |  | 200 | 200 | C | LND | XJ64 | J | 17 | X | IN | LND | 1760 |  |  |  |  |  |  |  | URMA |  |  |  |  |  |  |  | XJ30, XJ32, XJ39, XJ54, XJ70 | UDF_G2 |
| XJ801760 |  | CA17 PurgeColStr - Inspections/ Mech. Acceptance/ Loop Checks |  | 30d | 2012-10-05 | 2012-11-04 | XJ391760, XJ641760 FS-15d, XJ701760, EJ801760 (other project), XE601760, X030410030, X3J120 FF, IMS-C-000420 FF, XJ621760 | -111.5d | 5d |  | TB26 - 3 - Construction Normal 7days * CA17 | Loop Checks [220 pcs]; Loop checks [1100 h] | 44,000 | 1100,00 |  |  |  |  |  |  |  |  |  |  |  |  |  |  | XJ801760 | 1100 | 0 | 17 |  | X | J | 1760 |  | 2011-06-10 | 2012-04-30 | E-17-02-01 | 934 |  | 200 | 200 | C | LND | XJ80 | J | 17 | X | LT | LND | 1760 |  |  |  |  |  |  | 2012-08-18 | URMA |  |  |  |  | 2012-08-18 | 2012-03-01 |  | XE60, XJ39, XJ62, XJ64, XJ70 | UDF_G2 |

| ID | WBS | Activity | Type | Duration | Start | Finish | Predecessors | Complete | Planned start | Planned finish | Total float | Free float | Constraint | Calendar | Resources | Cost | Actual cost | TB26 Ressource Budget | UDF_SELECT | UDF_SELECT UPDATE PROGRESS | UDF_SAVE ACT ID | UDF_BUDGETED LABOR UNIT | UDF_ACTUAL LABOR UNIT | Department | Constr. Area | PMT-Area | PMT-Schedule Org | PMT-Phase | PMT-Respons. | WBS Phase | WBS Discipline | WBS Type of Work | WBS Objects | Russia WBS Discipline (Russia) | Russia Construction Area | Russia WBS Phase | IMS | UPT | Russia WBS Objects | UDF_CONTRACT FINISH DATE | UDF_CONTRACT ITEM | UDF_CONTRACT DATE PENALIZED | UDF_PENALIZED START | UDF_PENALIZED FINISH | Subcontractor | UDF_Concrete | UDF_CHECK BASELINE | Type of Work | Zeigen/n. Zeigen | UDF_CHECK CRITICAL PATH | TB26 Semantics | UDF_ELECTRICAL SEQUENCE | UDF_Text4 | Inquiry/Order No | UDF_BASELINE DEVELOPMENT |
| --- | --- | --- | --- | --- | --- | --- | --- | --- | --- | --- | --- | --- | --- | --- | --- | --- | --- | --- | --- | --- | --- | --- | --- | --- | --- | --- | --- | --- | --- | --- | --- | --- | --- | --- | --- | --- | --- | --- | --- | --- | --- | --- | --- | --- | --- | --- | --- | --- | --- | --- | --- | --- | --- | --- | --- |
|  | W | **Painting** |  |  | 2011-09-15 | 2011-10-19 |  |  |  |  |  |  |  |  |  |  |  |  |  |  |  |  |  |  |  |  |  |  |  |  |  |  |  |  |  |  |  |  |  |  |  |  |  |  |  |  |  |  |  |  |  |  |  |  |  |
| XW501760 |  | CA17 PurgeColStr - Surf.Protection Piping |  | 30d | 2011-09-15 | 2011-10-19 | XR201760 SS |  |  |  | 181.88d | 193.88d | start on or after 2011-09-15 |  | Piping painting [1056 sqm]; Piping painting [2640 h] | 1,537.3 |  | 2640,00 | OMUS-1 | 27.8. | XW501760 | 2640 | 0 | 934 | 17 | 200 | 200 | C | LND | X | W | XW50 | 1760 | W | 17 | X | PA | LND | 1760 |  |  |  |  |  |  |  |  |  |  |  |  |  |  |  |  |
|  | V | **Insulation** |  |  | 2011-12-21 | 2012-07-29 |  |  |  |  |  |  |  |  |  |  |  |  |  |  |  |  |  |  |  |  |  |  |  |  |  |  |  |  |  |  |  |  |  |  |  |  |  |  |  |  |  |  |  |  |  |  |  |  |  |
| XV301760 |  | CA17 PurgeColStr - Insulation Equipment |  | 80d | 2011-12-21 | 2012-03-18 | XB10176010 SS, XV300C00 SS |  |  |  | 66d | 80d |  | TB26 - 3 - Construction Normal 7days * CA17 | Equipment insulation [350 sqm]; Equipment insulation [4375 h] | 1,095.33 |  | 4375,00 | OMUS-1 |  | XV301760 | 4375 | 0 | 934 | 17 | 200 | 200 | C | LND | X | V | XV30 | 1760 | V | 17 | X | INS | LND | 1760 | 2012-03-30 | E-13-03 |  |  |  |  |  |  |  |  |  |  |  |  |  |  |
| XV501760 |  | CA17 PurgeColStr - Insulation Piping |  | 50d | 2012-06-09 | 2012-07-29 | XW501760 FF+12d, XR601760 SS+10d, XE801760 FF+20d, XV301760 |  |  |  | -14d | 102.5d |  | TB26 - 3 - Construction Normal 7days * CA17 | Piping insulation [900 sqm]; Piping insulation [6750 h] | 4,381.31 |  | 6750,00 | OMUS-1 |  | XV501760 | 6750 | 0 | 934 | 17 | 200 | 200 | C | LND | X | V | XV50 | 1760 | V | 17 | X | INS | LND | 1760 | 2012-04-30 | E-13-01 | P | 2012-06-09 | 2012-06-09 |  |  |  |  |  |  |  |  |  |  |  |
|  | 70 | **CA17 - Entrance Hall southside** |  |  | 2011-06-16 | 2012-07-24 |  |  |  |  |  |  |  |  |  |  |  |  |  |  |  |  |  |  |  |  |  |  |  |  |  |  |  |  |  |  |  |  |  |  |  |  |  |  |  |  |  |  |  |  |  |  |  |  |  |
|  | C | **Civil Work** |  |  | 2011-07-04 | 2012-07-24 |  |  |  |  |  |  |  |  |  |  |  |  |  |  |  |  |  |  |  |  |  |  |  |  |  |  |  |  |  |  |  |  |  |  |  |  |  |  |  |  |  |  |  |  |  |  |  |  |  |
| XC401770 |  | CA17 ExtrBldgEntrHall - Concrete Works Fdtn |  | 20d | 2011-07-04 A | 2011-07-23 A | XC40171026, EC481770 (other project) FS+20d, XC15170010 FS+44d, XC20171005 FS+30d | 100% | 2011-08-22 | 2011-09-10 |  |  | as late as possible | TB26 - 3 - Construction Normal 7days * CA17 | Concrete works [100 cbm]; Concrete works [3000 h] |  |  | 3000,00 | MTA |  | XC401770 | 3000 | 0 | 934 | 17 | 200 | 200 | C | MO03 | X | C | XC20 | 1770 | C | 17 | X | mis | LND | 1770 |  |  |  |  |  | MO11 |  |  |  |  |  |  |  |  |  |  |
| XC501770 |  | CA17 ExtrBldgEntrHall - Finishing Works |  | 45d | 2012-06-09 | 2012-07-24 | XC510C00 FS+15d, XN801770 FS-10d, IMS-C-000090 SS, XC500000 FF, IMS-C-000090 FF |  |  |  | 31d | 142.5d |  | TB26 - 3 - Construction Normal 7days * CA17 |  |  |  |  |  |  | XC501770 | 0 | 0 | 934 | 17 | 200 | 200 | C | CiC | X | C | XC50 | 1770 | C | 17 | X | EB | LND | 1770 |  |  |  |  |  |  | 1 |  |  |  |  |  |  |  |  |  |
|  | N | **Structural Steel** |  |  | 2011-06-16 | 2012-06-19 |  |  |  |  |  |  |  |  |  |  |  |  |  |  |  |  |  |  |  |  |  |  |  |  |  |  |  |  |  |  |  |  |  |  |  |  |  |  |  |  |  |  |  |  |  |  |  |  |  |
| XN701702 |  | CA17 ExtrBldgEntrHall SK1702 - KMD Assy Drawings | milestone | 0d | 2011-06-16 A | 2011-06-16 A |  | 100% |  |  |  |  | finish on 2011-06-16 | TB26 - 3 - Construction Normal 7days * CA17 |  |  |  | 22t |  |  | XN701702 | 0 | 0 | 934 | 17 | 200 | 200 | C | LND | X | N | XN05 | 1770 | N | 17 | X | SS | LND | 1770 |  |  |  |  |  |  |  | x | XNK | KMD |  |  |  |  |  |  |
| XN711702 |  | CA17 ExtrBldgEntrHall SK1702 - Steel Deliveries | milestone | 0d | 2011-08-31 | 2011-08-31 |  |  |  |  | 0d | 155d | finish on 2011-08-31 | TB26 - 3 - Construction Normal 7days * CA17 |  |  |  | 22t |  |  | XN711702 | 0 | 0 | 934 | 17 | 200 | 200 | C | LND | X | N | XN06 | 1770 | N | 17 | X | SS | LND | 1770 |  |  |  |  |  |  |  |  | XNK | SD |  |  |  |  |  |  |
| XN201770 |  | CA17 ExtrBldgEntrHall SK1702 - Erection Primary Steel |  | 60d | 2012-02-21 | 2012-04-22 | XN701702, XC401770, XN711702 FS+10d, XN801710 SS+10d, IMS-C-000150 FF, P3N02SN (other project), XC40174015 |  |  |  | 31d | 0d |  | TB26 - 3 - Construction Normal 7days * CA17 | Piperacks, Main Structures [350 t]; Grating [500 sqm]; Ladders & platforms [26 t]; Piperacks, Main structures [14875 h]; Grating [1875 h]; Ladders & platforms [2600 h] | 774,000 |  | 19350,00 | OMUS-1 |  | XN201770 | 19350 | 0 | 934 | 17 | 200 | 200 | C | LND | X | N | XN20 | 1770 | N | 17 | X | SS | LND | 1770 |  | E-04-20 |  |  |  | SM |  |  | XNK |  | zu spaet wg cable trays | t | Trays + Pulling fehlt |  |  |  |
| XN801770 |  | CA17 ExtrBldgEntrHall SK1702 - Install Cladding |  | 60d | 2012-04-18 | 2012-06-19 | EN801702 (other project), XN201770 FF+25d, XN201770 FS-5d |  |  |  | 31d | 0d |  | TB26 - 3 - Construction Normal 7days * CA17 | Cladding [1610 sqm]; Cladding [8050 h] | 3,991.08 |  | 8050,00 | OMUS-1 |  | XN801770 | 8050 | 0 | 934 | 17 | 200 | 200 | C | LND | X | N | XN80 | 1770 | N | 17 | X | SS | LND | 1770 |  |  |  |  |  | SM |  |  | XNK |  |  |  |  |  |  |  |
|  | H | **HVAC** |  |  |  |  |  |  |  |  |  |  |  |  |  |  |  |  |  |  |  |  |  |  |  |  |  |  |  |  |  |  |  |  |  |  |  |  |  |  |  |  |  |  |  |  |  |  |  |  |  |  |  |  |  |
|  | 18 | **CA18 - Chiller Unit** |  |  | 2012-04-23 | 2012-07-31 |  |  |  |  |  |  |  |  |  |  |  |  |  |  |  |  |  |  |  |  |  |  |  |  |  |  |  |  |  |  |  |  |  |  |  |  |  |  |  |  |  |  |  |  |  |  |  |  |  |
|  | 00.0B | **CA18 - General** |  |  | 2012-04-23 | 2012-07-31 |  |  |  |  |  |  |  |  |  |  |  |  |  |  |  |  |  |  |  |  |  |  |  |  |  |  |  |  |  |  |  |  |  |  |  |  |  |  |  |  |  |  |  |  |  |  |  |  |  |
| XC101800 |  | CA18 Chiller Unit - Civil works |  | 99d | 2012-04-23 | 2012-07-31 |  |  |  |  | 249.5d | 0d | start on or after 2012-04-23 | TB26 - 2 - Manuf and Delivy | Concrete works [150 cbm]; Concrete works [4500 h]; Piperacks, Main Structures [8 t]; Piperacks, Main structures [340 h]; Ladders & platforms [1 t]; Ladders & platforms [100 h]; Grating [10 sqm]; Grating [37.5 h]; A/G piping prefabrication [50 Fpi]; A/G Piping (Prefab) [187.5 h]; Singlecore cables [1200 m]; Piping insulation [50 sqm]; Piping insulation [375 h]; Electrical heat tracing [50 h]; Lighting illuminates [30 pcs]; Lighting (iluminates) [300 h]; Multicore cables [400 m]; Pull multicore cables [200 h]; Secondary cable trays [50 m]; Install secondary cable trays [187.5 h]; Pull singlecore cables [900 h]; Electrical Heat Tracing [100 m]; Install Control & Shut-off Valves [26.25 h]; Loop Checks [50 pcs]; Loop checks [250 h]; Control & Shut-off valves [5 pcs]; Piles driven [50 pcs]; Piles driven [375 h]; Cable trays/conduits [20 m]; Cable trays [60 h]; A/G Piping (Field) [312.5 h]; A/G piping field installation [50 Fpi]; Cable Pulling [600 m]; Cable pulling [300 h]; Cable connecting [40 pcs]; Cable connecting [100 h] | 344,050 |  | 8601,25 |  |  | XC101800 | 8601,25 | 0 | 934 | 18 | 200 | 200 | C | LND | X | 0B | XC00 | 1810 | 0 |  | X | MC | LND |  |  |  |  |  |  |  |  |  |  |  |  |  |  |  |  |  |
|  | 31 | **CA31 - Blenders & Storage Silos / Packaging & Shipping** |  |  | 2008-09-24 | 2012-11-16 |  |  |  |  |  |  |  |  |  |  |  |  |  |  |  |  |  |  |  |  |  |  |  |  |  |  |  |  |  |  |  |  |  |  |  |  |  |  |  |  |  |  |  |  |  |  |  |  |  |
|  | 00 | **CA31 - General** |  |  | 2008-09-24 | 2012-11-16 |  |  |  |  |  |  |  |  |  |  |  |  |  |  |  |  |  |  |  |  |  |  |  |  |  |  |  |  |  |  |  |  |  |  |  |  |  |  |  |  |  |  |  |  |  |  |  |  |  |
|  | 0B | **General Activities** |  |  | 2012-10-19 | 2012-11-16 |  |  |  |  |  |  |  |  |  |  |  |  |  |  |  |  |  |  |  |  |  |  |  |  |  |  |  |  |  |  |  |  |  |  |  |  |  |  |  |  |  |  |  |  |  |  |  |  |  |
| X0103110 |  | CA31 General - Construction Completion | milestone | 0d | 2012-10-19 | 2012-10-19 | XH00312005, XH00313005, XR403140, XE703140, XJ543140, MI-21502, XR403110, XE703110, XJ393110, XJ523130, XN603110, XJ643110, XJ703110, XN403120, XE50313020, XE603140, XM103120, XE913120, XM003110, XE603110, XH00312006, XR403120, XE703130, XB003140, XE913140, XC803120, XC803130, XC803140, XH00311005, XE913110, XB003120, RF-21515, XX-21501-BL01, XX-22501-BL01, XE603120, XJ543120, XE913130, XM003140, XN403110, XN603120, XE703120, XE803120, XJ643120, XR403130, XJ643140, XJ623140, XC503110, XN803110, MI-21501, RF-21516, XJ513130, XJ613130, XC193118, XB50311020, XH00311005_1 |  |  |  | -111d | 0.5d |  | TB26 - 2 - Manuf and Delivy |  |  |  |  |  |  | X0103110 | 0 | 0 | 934 | 31 | 200 | 200 | C | LND | X | 0B | X010 | 3100 | 0 | 31 | X | MC | LND | 3100 |  |  |  |  |  |  |  |  | XNK | C7 |  |  |  | CA16 - critical - CW05 | 2DC8990 |  |
| X0103100 |  | CA31 General - Mechanical Completion | milestone | 0d | 2012-11-16 | 2012-11-16 | XC603110, XH00311010, XJ803110, XV503120, XC803120, XE913110, XH00312006, XE603120, XV303120, XH00313006, XH00314010, XC603100, XH00312010, XE913120, XJ803120, XH00313015, XE603140, XJ803140, XC803110, XH00313010, XW503140, X0103110, XE703110, XE703120, XC50313005, XE703130, XE703140, XC803130, XV303110, XV503110, XJ613130, XW503130, XC803140, XE603110, XC503120, XC503130, XE913130, XC503140, XC503110, XE913140, XB50311020, XJ803130, XJ803130 (other project) |  |  |  | -83.5d | 43d |  | TB26 - 2 - Manuf and Delivy |  |  |  |  |  |  | X0103100 | 0 | 0 | 934 | 31 | 200 | 200 | C | LND | X | 0B | X010 | 3100 | 0 | 31 | X | MC | LND | 3100 |  |  |  |  |  |  |  |  | XNK | C7 |  |  |  | CA16 - critical - CW05 | 2DC8990 |  |
|  | C | **Civil Work** |  |  | 2008-09-24 | 2012-04-30 |  |  |  |  |  |  |  |  |  |  |  |  |  |  |  |  |  |  |  |  |  |  |  |  |  |  |  |  |  |  |  |  |  |  |  |  |  |  |  |  |  |  |  |  |  |  |  |  |  |
| XC113100 |  | CA31 General - Excavation&Surface Prep by U/I/O |  | 294d | 2008-09-24 A | 2009-09-30 A | XC111510 SS | 100% |  |  |  |  |  |  |  |  |  |  |  |  | XC113100 | 0 | 0 | 934 | 31 | 200 | 200 | C | UIO | X | C | XC11 | 3100 | C | 31 | X | CW | LND | 3100 |  |  |  |  |  | MO11 |  |  |  |  |  |  |  |  |  |  |
| XC11310005 |  | CA31 General - Excavation |  | 51d | 2009-10-05 A | 2009-12-02 A | XC113100 | 100% |  |  |  |  |  |  | Excavation [6747 cbm]; Excavation [3373.5 h] | 269,880 | 269,880 | 3373,50 |  |  | XC11310005 | 3373,5 | 3373,5 | 934 | 31 | 200 | 200 | C | UIO | X | C | XC11 | 3100 | C | 31 | X | CW | LND | 3100 |  |  |  |  |  | MO11 |  |  |  |  |  |  |  |  |  |  |
| XC603100 |  | CA31 General - Paving outside / Aphalt Road |  | 40d | 2012-03-12 | 2012-04-30 | XC603120 FS+95d, IMS-C-000120 FF, XC193115 FF+15d, XC193120, XC193110 SS+10d |  |  |  | 97d | 167.5d | start on or after 2012-03-12 | TB26 - T - Construct-Winter-3 (Dec/Jan/Feb free) * | Asphalt roads; Open ditches; Gravel [8600 sqm]; Asphalt Roads; open ditches; Gravel [430 h] | 17,200 |  | 430,00 |  |  | XC603100 | 430 | 0 | 934 | 31 | 200 | 200 | C | MO04 | X | C | XC60 | 3100 | C | 31 | X | PV | LND | 3110 |  |  |  |  |  | MO11 | 1 |  |  |  |  |  |  |  |  | XC303110 |

Notes:
- XW501760: P3 Activity Log Info: Clarification Surface Protection during Prefab
- XN711702: Scope: 09.02.2011: weight: 350 ton / Current Status: 21.06.2011 (O.Siegel) Info von Frau / Schilka, dass Stahl nicht vor dem 20.08.11 auf der Baustelle ankommen wird. so / dass die Montage der Stahlkonstruktionen erst ab 31.08.11 mцglich sein / wird.
- XC113100: P3 Activity Log Info: incl. Dewatering/Drainage
- XC11310005: P3 Activity Log Info: incl. Dewatering/Drainage

| ID | WBS | Activity | Type | Duration | Start | Finish | Predecessors | Complete | Planned start | Planned finish | Total float | Free float | Constraint | Calendar | Resources | Cost | Actual cost | TB26 Ressource Budget | UDF_SAVE ACT ID | UDF_BUDGETED LABOR UNIT | UDF_ACTUAL LABOR UNIT | Department | Constr. Area | PMT-Area | PMT-Schedule Org | PMT-Phase | PMT-Respons. | WBS Phase | WBS Discipline | WBS Type of Work | WBS Objects | Russia WBS Discipline (Russia) | Russia Construction Area | Russia WBS Phase | IMS | UPT | Russia WBS Objects | Subcontractor | Civil item | UDF_CHECK CRITICAL PATH | UDF_SELECT UPDATE PROGRESS | Zeigen/n. Zeigen | 4 week lookahead | suspend date | resume date | UDF_CHECK RESOURCE DATES | UDF_CONTRACT INDICATOR | MTA | Check ResLoading | UDF_TB26 Sequence | UDF_PLANNED START | UDF_PLANNED FINISH | UDF_EXPECTED START | UDF_EXPECTED FINISH | UDF_Text4 | UDF_SELECT | UDF_CONTRACT DATE PENALIZED | UDF_PENALIZED START | UDF_PENALIZED FINISH | UDF_Concrete | UDF_BASELINE DEVELOPMENT | Filter | UDF_CHECK BASELINE |
| --- | --- | --- | --- | --- | --- | --- | --- | --- | --- | --- | --- | --- | --- | --- | --- | --- | --- | --- | --- | --- | --- | --- | --- | --- | --- | --- | --- | --- | --- | --- | --- | --- | --- | --- | --- | --- | --- | --- | --- | --- | --- | --- | --- | --- | --- | --- | --- | --- | --- | --- | --- | --- | --- | --- | --- | --- | --- | --- | --- | --- | --- | --- | --- |
|  | 04 | **CA31 - Auxiliary Structures Zeppelin** |  |  |  |  |  |  |  |  |  |  |  |  |  |  |  |  |  |  |  |  |  |  |  |  |  |  |  |  |  |  |  |  |  |  |  |  |  |  |  |  |  |  |  |  |  |  |  |  |  |  |  |  |  |  |  |  |  |  |  |  |  |
|  | 10 | **CA31(3101) - Silo Structure** |  |  | 2009-11-07 | 2012-11-16 |  |  |  |  |  |  |  |  |  |  |  |  |  |  |  |  |  |  |  |  |  |  |  |  |  |  |  |  |  |  |  |  |  |  |  |  |  |  |  |  |  |  |  |  |  |  |  |  |  |  |  |  |  |  |  |  |  |
|  | C | **Civil Work** |  |  | 2009-11-07 | 2012-05-16 |  |  |  |  |  |  |  |  |  |  |  |  |  |  |  |  |  |  |  |  |  |  |  |  |  |  |  |  |  |  |  |  |  |  |  |  |  |  |  |  |  |  |  |  |  |  |  |  |  |  |  |  |  |  |  |  |  |
| XC153110 |  | CA31 SiloStruc - Piling |  | 88d | 2009-11-07 A | 2010-02-17 A | EC153110 (other project) FS+5d, F2910, XC11310005 FF, XC113100, P3C01D (other project) | 100% |  |  |  |  |  |  | Piles driven [376 pcs]; Piles driven [2820 h] | 3,325.9 |  | 2820,00 | XC153110 | 2820 | 2820 | 934 | 31 | 200 | 200 | C | MO01 | X | C | XC15 | 3110 | C | 31 | X | P | LND | 3110 | MO11 |  |  |  |  |  |  |  |  |  |  |  |  |  |  |  |  |  |  |  |  |  |  |  |  |  |
| XC20311005 |  | CA31 SiloStruc - Concrete Works Fdtn |  | 241d | 2010-05-31 A | 2011-05-14 A | EC28311005 (other project), EC45311515 (other project) FF+20d, XC153110, P3C02D1 (other project), EC28311003 (other project) FS+15d, XC200C10, EC283115 (other project) FF | 100% |  |  |  |  |  | TB26 - V - Construct-Winter partly * | Concrete works [1370 cbm]; Concrete works [41100 h] | 21,840.05 |  | 41100,00 | XC20311005 | 41100 | 41100 | 934 | 31 | 200 | 200 | C | MO03 | X | C | XC20 | 3110 | C | 31 | X | mai | LND | 3110 | MO11 |  |  |  |  |  |  |  |  |  |  |  |  |  |  |  |  |  |  |  |  |  |  |  |  |  |
| XC40311015 |  | CA31 SiloStruc - Concrete Works Columns/Walls |  | 179d | 2010-10-11 A | 2011-07-15 A | EC45311015 (other project), EC45311005 (other project) FF, EC28311007 (other project), F2860 FF, P3C02D3 (other project) FF, EC28311005 (other project), XC20311007, XC20311005 FS-6d | 100% |  |  |  |  |  | TB26 - V - Construct-Winter partly * | Concrete works [1690 cbm]; Concrete works [50700 h] | 3,281.55 |  | 50700,00 | XC40311015 | 50700 | 30000 | 934 | 31 | 200 | 200 | C | MO04 | X | C | XC40 | 3110 | C | 31 | X | OB | LND | 3110 | MO11 | x | Silo | x | C7 | x |  |  |  |  |  |  |  |  |  |  |  |  |  |  |  |  |  |  |  |  |
| XC193110 |  | CA31 SiloStruc - Backfill |  | 319d | 2010-10-19 A | 2011-08-08 A | XC303110 FF+15d, XC913110 FF+20d | 100% | 2010-10-19 | 2012-05-31 |  |  |  | TB26 - T - Construct-Winter-3 (Dec/Jan/Feb free) * | Backfill & Compaction [2100 cbm]; Backfill & Compaction [3150 h] | 189,000 | 189,000 | 3150,00 | XC193110 | 3150 | 3150 | 934 | 31 | 200 | 200 | C | MO04 | X | C | XC19 | 3110 | C | 31 | X | UG | LND | 3110 | MO11 |  |  | 27.8. | D |  | 2010-11-01 | 2010-11-30 | x |  |  |  |  |  |  |  |  |  |  |  |  |  |  |  |  |  |
| XC40311020 |  | CA31 SiloStruc SK3101 - Concrete Works Ceiling all floors |  | 196d | 2010-12-15 A | 2011-08-25 A | XC40311017 FF+17d, XC40311015 FF, EC28311010 (other project), EC28311012 (other project) FF, EC28311007 (other project) | 100% | 2010-12-15 | 2011-08-13 |  |  |  |  | Concrete works [3280 cbm]; Concrete works [98400 h] | 3,936,000 | 2,570,400 | 98400,00 | XC40311020 | 98400 | 67269 | 934 | 31 | 200 | 200 | C | MO04 | X | C | XC40 | 3110 | C | 31 | X | OB | LND | 3110 | MO11 | x | Silo | 27.8. | C7 | x |  |  |  | UDF_G4 | MTA | X |  |  |  |  |  |  |  |  |  |  |  |  |  |  |
| XC40311015_010 |  | CA31 SiloStruc - Concrete Works Columns / Ceiling Level 1 (1) |  | 11d | 2011-01-10 A | 2011-02-01 A |  | 100% |  |  |  |  |  | TB26 - V - Construct-Winter partly * |  |  |  | 650 | XC40311015_010 | 0 | 0 | 934 | 31 | 200 | 200 | C | MO04 | X | C | XC40 | 3110 | C | 31 | X | OB | LND | 3110 | MO11 |  | Silo |  | L4 |  |  |  |  |  |  |  | 1 |  |  |  |  |  |  |  |  |  |  |  |  |  |
| XC40311015_020 |  | CA31 SiloStruc - Concrete Works Columns Level 1/2 (2) |  | 35d | 2011-02-01 A | 2011-04-02 A | XC40311015_010 | 100% |  |  |  |  |  | TB26 - V - Construct-Winter partly * |  |  |  | 650 | XC40311015_020 | 0 | 0 | 934 | 31 | 200 | 200 | C | MO04 | X | C | XC40 | 3110 | C | 31 | X | OB | LND | 3110 | MO11 |  | Silo |  | L4 |  |  |  |  |  |  |  | 2 | 2011-03-01 | 2011-03-13 | 2011-02-01 | 2011-03-30 |  |  |  |  |  |  |  |  |  |
| XC40311015_030 |  | CA31 SiloStruc - Concrete Works Ceiling Level 1/2 (3) |  | 25d | 2011-02-28 A | 2011-04-02 A | XC40311015_020 | 100% |  |  |  |  |  | TB26 - V - Construct-Winter partly * |  |  |  | 650 | XC40311015_030 | 0 | 0 | 934 | 31 | 200 | 200 | C | MO04 | X | C | XC40 | 3110 | C | 31 | X | OB | LND | 3110 | MO11 |  | Silo |  | L4 |  |  |  |  |  |  |  | 3 |  |  | 2011-02-28 | 2011-03-28 |  |  |  |  |  |  |  |  |  |
| XC40311010 |  | CA31 SiloStruc - Precast Concrete Elements |  | 10d | 2011-03-14 A | 2011-07-15 A | EC28311009 (other project), P3C02D3 (other project) FF, EC28311004 (other project), P3C02D2 (other project) | 100% | 2011-06-25 | 2011-07-06 |  |  | start on or after 2011-03-14 |  |  |  |  |  | XC40311010 | 0 | 0 | 934 | 31 | 200 | 200 | C | MO04 | X | C | XC40 | 3110 | C | 31 | X | pre | LND | 3120 | MO11 |  |  | x | C7 | x |  |  |  |  |  |  |  |  |  |  |  |  |  |  |  |  |  |  |  |  |
| XC40311015_040 |  | CA31 SiloStruc - Concrete Works 14 Columns Level 2 Finished (4) |  | 24d | 2011-04-09 A | 2011-05-07 A | XC40311015_030 | 100% |  |  |  |  |  |  |  |  |  | 650 | XC40311015_040 | 0 | 0 | 934 | 31 | 200 | 200 | C | MO04 | X | C | XC40 | 3110 | C | 31 | X | OB | LND | 3110 | MO11 |  | Silo |  | L4 |  |  |  |  |  |  |  | 4 |  |  |  |  |  |  |  |  |  |  |  |  |  |
| XC40311015_050 |  | CA31 SiloStruc - Concrete Works Ceiling Level 2 Finished / 14 Columns Level 3 (5) |  | 29d | 2011-04-09 A | 2011-05-14 A | XC40311015_030 | 100% |  |  |  |  |  |  |  |  |  | 650 | XC40311015_050 | 0 | 0 | 934 | 31 | 200 | 200 | C | MO04 | X | C | XC40 | 3110 | C | 31 | X | OB | LND | 3110 | MO11 |  | Silo |  | L4 |  |  |  |  |  |  |  | 5 |  |  |  |  |  |  |  |  |  |  |  |  |  |
| XC40311015_060 |  | CA31 SiloStruc - Concrete Works 21 Columns Level 3 (6) |  | 64d | 2011-04-25 A | 2011-07-11 A | XC40311015_050 FS-35d | 100% |  |  |  |  |  |  |  |  |  | 650 | XC40311015_060 | 0 | 0 | 934 | 31 | 200 | 200 | C | MO04 | X | C | XC40 | 3110 | C | 31 | X | OB | LND | 3110 |  |  | Silo |  | L4 |  |  |  |  |  |  |  | 6 |  |  |  |  |  |  |  |  |  |  |  |  |  |
| XC20311007 |  | CA31 SiloStruc - Concrete Works Fdtn finished | milestone | 0d | 2011-05-14 A | 2011-05-14 A | XC20311005 FF | 100% |  |  |  |  |  | TB26 - V - Construct-Winter partly * |  |  |  |  | XC20311007 | 0 | 0 | 934 | 31 | 200 | 200 | C | MO03 | X | C | XC20 | 3110 | C | 12 | X | mai | LND | 1201 | MO11 |  |  |  |  |  |  |  |  |  |  |  |  |  |  |  |  |  |  |  |  |  |  |  |  |  |
| XC40311017 |  | CA31 SiloStruc - Erection Precast Elements |  | 26d | 2011-06-25 A | 2011-07-26 A | XC40311015 FF-15d, XC40311010 FS-7d | 100% | 2011-06-25 | 2011-07-25 |  |  |  |  | Precast Concrete Works [1470 cbm]; Precast concrete works [3675 h] | 147,000 | 43,842.11 | 3675,00 | XC40311017 | 3675 | 0 | 934 | 31 | 200 | 200 | C | MO04 | X | C | XC40 | 3110 | C | 31 | X | OB | LND | 3120 | MO11 |  | Silo |  | C7 |  |  |  |  | UDF_G4 |  |  |  |  |  |  |  | CA16 - critical - CW05 |  |  |  |  |  |  |  |  |
| XC40311015_070 |  | CA31 SiloStruc - Concrete Works Precast Beams Level 3 (7) |  | 20d | 2011-06-29 A | 2011-07-21 A | XC40311015_060 FS-2d | 100% |  |  |  |  |  |  |  |  |  |  | XC40311015_070 | 0 | 0 | 934 | 31 | 200 | 200 | C | MO04 | X | C | XC40 | 3110 | C | 31 | X | OB | LND | 3110 |  |  | Silo |  | L4 |  |  |  |  | UDF_G4 |  |  | 7 |  |  |  |  |  |  |  |  |  |  |  |  |  |
| XC40311015_080 |  | CA31 SiloStruc - Concrete Works Precast Silo Base Beams (8) incl. in-situ areas |  | 25d | 2011-07-13 A | 2011-08-18 A | XC40311015_070 SS+15d | 100% | 2011-07-13 | 2011-08-10 |  |  |  |  |  |  |  |  | XC40311015_080 | 0 | 0 | 934 | 31 | 200 | 200 | C | MO04 | X | C | XC40 | 3110 | C | 31 | X | OB | LND | 3110 |  |  | Silo | 27.8. | L4 |  |  |  |  | UDF_G4 |  |  | 8 |  |  |  |  |  |  |  |  |  |  |  |  |  |
| XC40311022 |  | CA31 SiloStruc - Concrete Works Ceiling all floors finished | milestone | 0d | 2011-08-25 A | 2011-08-25 A | XC40311015_080, XC40311020 FF | 100% |  |  |  |  |  |  |  |  |  |  | XC40311022 | 0 | 0 | 934 | 31 | 200 | 200 | C | MO04 | X | C | XC40 | 3110 | C | 31 | X | EB | LND | 1710 | MO11 |  | Silo | 27.8. | D |  |  |  |  |  |  |  | . |  |  |  |  |  | MTA | P | 2011-06-30 | 2011-06-30 |  |  |  |  |
| XC303110 |  | CA31 General - UG Installation (incl. Precast Manholes) |  | 30d | 2011-09-12 | 2011-10-15 | P3R02BS (other project), EC303110 (other project) FS+10d, XC300C00, P3R02AS1 (other project), ER443110 (other project), XC300C00 SS, P3R02S1 (other project), XC310C00, P3R02S1 (other project) FF |  |  |  | -109d | 0d | start on or after 2011-09-12 |  | Concrete Manholes [49 pcs]; Floor Drains / Catch Basins [7 pcs]; FRP U/G Piping [375 m]; concrete manholes [13475 h]; floor drains / catch basins [175 h]; FRP U/G piping [4687.5 h] | 733,500 |  | 36675,00 | XC303110 | 18337,5 | 0 | 934 | 31 | 200 | 200 | C | CiC | X | C | XC30 | 3100 | C | 31 | X | UG | LND | 3100 |  |  | XC303110 | 27.8. | C5 |  |  |  |  |  |  | UG |  |  |  |  |  |  |  |  |  |  | 1 | XC303110 |  |  |
| XC193115 |  | CA31 SiloStruc - Backfill |  | 30d | 2011-10-17 | 2011-11-29 | XC303110 SS+30d |  |  |  | -35d | 0d |  | TB26 - T - Construct-Winter-3 (Dec/Jan/Feb free) * | Backfill & Compaction [2000 cbm]; Backfill & Compaction [3000 h] | 180,000 |  | 6000,00 | XC193115 | 3000 | 0 | 934 | 31 | 200 | 200 | C | MO04 | X | C | XC19 | 3110 | C | 31 | X | UG | LND | 3110 | MO11 |  |  |  | D |  | 2010-11-01 | 2010-11-30 |  |  |  |  |  |  |  |  |  |  |  |  |  |  |  | XC303140 | 1 | x |
| XC603110 |  | CA31 SiloStruc - Paving inside |  | 40d | 2011-10-28 | 2011-12-14 | XC193110 SS+45d, EC603110 (other project) FS+15d, XC193115 SS+10d |  |  |  | -35d | 0d |  |  | Concrete paved areas & concrete Roads [2900 sqm]; Concrete paved areas & concrete roads [10875 h] | 10,550.48 |  | 10875,00 | XC603110 | 10875 | 0 | 934 | 31 | 200 | 200 | C | MO04 | X | C | XC60 | 3110 | C | 31 | X | PV | LND | 3110 | MO11 |  |  |  |  |  |  |  |  |  |  |  |  |  |  |  |  |  |  |  |  |  | 1 |  |  |  |
| XC503110 |  | CA31 SiloStruc - Finishing Work Bagging Sec |  | 120d | 2011-11-22 | 2012-04-18 | XN803110S SS+10d, XC003110 FF+60d, XC510C00 FS+15d, EC503110 (other project), XC603110 FS-20d, XN803110 SS+10d, P3A06AS3 (other project), XB50311010 |  |  |  | 20d | 0d |  |  | Finishing Works - Warehouse CA31 [17915 mhr]; Finishing Works - Warehouse CA31 [17915 h] | 1,791,500 |  | 17915,00 | XC503110 | 17915 | 0 | 934 | 31 | 200 | 200 | C | CiC | X | C | XC50 | 3110 | C | 31 | X | OB | LND | 3110 |  |  |  |  |  |  |  |  |  |  |  | 31 |  |  |  |  |  |  | XC50 |  |  |  | 1 |  | x |  |
| XC503110_1 |  | CA31 SiloStruc - Plastering and Painting Bagging Sec |  | 30d | 2011-11-22 | 2011-12-26 | XC503110 SS |  |  |  | 20d | 0d |  |  |  |  |  | 17915,00 | XC503110 | 17915 | 0 | 934 | 31 | 200 | 200 | C | CiC | X | C | XC50 | 3110 | C | 31 | X | OB | LND | 3110 |  |  |  |  |  |  |  |  |  |  |  | 31 |  |  |  |  |  |  |  |  |  |  | 1 |  | x |  |
| XC303115 |  | CA31 General - UG Installation (incl. Precast Manholes) |  | 30d | 2012-03-03 | 2012-04-09 |  |  |  |  | 38.46d | 0d | start on or after 2012-03-03 |  | Concrete Manholes [49 pcs]; Floor Drains / Catch Basins [7 pcs]; FRP U/G Piping [375 m]; concrete manholes [13475 h]; floor drains / catch basins [175 h]; FRP U/G piping [4687.5 h] | 733,500 |  | 36675,00 | XC303110 | 18337,5 | 0 | 934 | 31 | 200 | 200 | C | CiC | X | C | XC30 | 3100 | C | 31 | X | UG | LND | 3100 |  |  | XC303110 |  | C5 |  |  |  |  |  |  | UG |  |  |  |  |  |  |  |  |  |  | 1 | XC303110 |  |  |
| XC193118 |  | CA31 SiloStruc - Backfill |  | 30d | 2012-04-09 | 2012-05-16 | XC303115 |  |  |  | 38.46d | 133.46d |  | TB26 - T - Construct-Winter-3 (Dec/Jan/Feb free) * | Backfill & Compaction [2000 cbm]; Backfill & Compaction [3000 h] | 180,000 |  | 6000,00 | XC193115 | 3000 | 0 | 934 | 31 | 200 | 200 | C | MO04 | X | C | XC19 | 3110 | C | 31 | X | UG | LND | 3110 | MO11 |  |  |  | D |  | 2010-11-01 | 2010-11-30 |  |  |  |  |  |  |  |  |  |  |  |  |  |  |  | XC303110 | 1 | x |

Notes:
- XC153110: P3 Activity Log Info: 150 bored piles d=120cm, 2/d/machine
- XC40311015: Current Status: 19.02.2011 (O.Siegel): Endtermin am 21-Mrz-11 wird als / gefдhrdet eingestuft.
- XC40311020: Current Status: 12.01.2011 (Oxana): Endtermin auf den 01-05-2011 geдndert / (Absprache mit Mostostroy am 11.01.2011).
- XC40311015_020: Current Status: 14.03.2011 (O.Siegel): die Schalung fьr die Decke Level 2 / wird anschlieЯend fьr die Zwischenwдnde unterhalb der Level 1 / Decke.
- XC40311010: Current Status: 110212 Set Contraint 3.3.11 (WL)
- XC303110: P3 Activity Log Info: Clarification Prefab / Catch Basins/pulling pits
- XC303115: P3 Activity Log Info: Clarification Prefab / Catch Basins/pulling pits

| ID | WBS | Activity | Type | Duration | Start | Finish | Predecessors | Complete | Remaining | Planned start | Planned finish | Total float | Free float | Constraint | Calendar | Resources | Cost | TB26 Ressource Budget | UDF_SAVE ACT ID | UDF_CHECK BASELINE | UDF_BUDGETED LABOR UNIT | UDF_ACTUAL LABOR UNIT | Department | Type of Work | Constr. Area | PMT-Area | PMT-Schedule Org | PMT-Phase | PMT-Respons. | Zeigen/n. Zeigen | WBS Phase | WBS Discipline | WBS Type of Work | WBS Objects | Russia WBS Discipline (Russia) | Russia Construction Area | Russia WBS Phase | IMS | UPT | Russia WBS Objects | UDF_CONTRACT ITEM | UDF_CHECK CRITICAL PATH | TB26 Semantics | UDF_SELECT UPDATE PROGRESS | Inquiry/Order No | UDF_SELECT | UDF_CONTRACT INDICATOR | UDF_CHECK RESOURCE DATES | Subcontractor | MTA | UDF_TB26 Sequence | Filter | UDF_CONTRACT START DATE | UDF_CONTRACT FINISH DATE | UDF_L3 START DATE | UDF_L3 FINISH DATE | Check ResLoading |
| --- | --- | --- | --- | --- | --- | --- | --- | --- | --- | --- | --- | --- | --- | --- | --- | --- | --- | --- | --- | --- | --- | --- | --- | --- | --- | --- | --- | --- | --- | --- | --- | --- | --- | --- | --- | --- | --- | --- | --- | --- | --- | --- | --- | --- | --- | --- | --- | --- | --- | --- | --- | --- | --- | --- | --- | --- | --- |
|  | N | **Structural Steel** |  |  | 2011-02-10 | 2012-01-16 |  |  |  |  |  |  |  |  |  |  |  |  |  |  |  |  |  |  |  |  |  |  |  |  |  |  |  |  |  |  |  |  |  |  |  |  |  |  |  |  |  |  |  |  |  |  |  |  |  |  |  |
| XN743101 |  | CA31 SiloStruc SK3101_30 - KMD Assy Drawings | milestone | 0d | 2011-02-10 A | 2011-02-10 A |  | 100% |  |  |  |  |  | finish on 2011-02-10 |  |  |  | 22t | XN743101 | x | 0 | 0 | 934 | XNK | 31 | 200 | 200 | C | LND | KMD | X | N | XN05 | 3110 | N | 31 | X | SS | LND | 3110 |  |  |  |  |  |  |  |  |  |  |  |  |  |  |  |  |  |
| XN703100 |  | CA31 General - KMD Assy Drawings | milestone | 0d | 2011-03-01 A | 2011-03-01 A |  | 100% |  |  |  |  |  | finish on 2011-03-01 |  |  |  | 22t | XN703100 | x | 0 | 0 | 934 | XNK | 31 | 200 | 200 | C | LND | KMD | X | N | XN05 | 3100 | N | 31 | X | SS | LND | 3100 |  |  |  |  |  |  |  |  |  |  |  |  |  |  |  |  |  |
| XN703101 |  | CA31 SiloStruc SK3101_01-05 - KMD Assy Drawings | milestone | 0d | 2011-03-10 A | 2011-03-10 A |  | 100% |  |  |  |  |  | finish on 2011-03-10 |  |  |  | 22t | XN703101 | x | 0 | 0 | 934 | XNK | 31 | 200 | 200 | C | LND | KMD | X | N | XN05 | 3110 | N | 31 | X | SS | LND | 3110 |  |  |  |  |  |  |  |  |  |  |  |  |  |  |  |  |  |
| XN703105 |  | CA31 SiloStruc SK3105 - KMD Assy Drawings | milestone | 0d | 2011-03-10 A | 2011-03-10 A |  | 100% |  |  |  |  |  | finish on 2011-03-10 |  |  |  | 22t | XN703105 | x | 0 | 0 | 934 | XNK | 31 | 200 | 200 | C | LND | KMD | X | N | XN05 | 3110 | N | 31 | X | SS | LND | 3110 |  |  |  |  |  |  |  |  |  |  |  |  |  |  |  |  |  |
| XN723101 |  | CA31 SiloStruc SK3101_06-13 - KMD Assy Drawings | milestone | 0d | 2011-03-10 A | 2011-03-10 A |  | 100% |  |  |  |  |  | finish on 2011-03-10 |  |  |  | 22t | XN723101 | x | 0 | 0 | 934 | XNK | 31 | 200 | 200 | C | LND | KMD | X | N | XN05 | 3110 | N | 31 | X | SS | LND | 3110 |  |  |  |  |  |  |  |  |  |  |  |  |  |  |  |  |  |
| XN713100 |  | CA31 General - Steel Deliveries | milestone | 0d | 2011-03-27 A | 2011-03-27 A |  | 100% |  |  |  |  |  | finish on 2011-03-09 | TB26 - 3 - Construction Normal 7days * CA17 |  |  | 22t | XN713100 |  | 0 | 0 | 934 | XNK | 31 | 200 | 200 | C | LND | SD | X | N | XN06 | 3100 | N | 31 | X | SS | LND | 3100 |  |  |  |  |  |  |  |  |  |  |  |  |  |  |  |  |  |
| XN703106 |  | CA31 SK3106 - KMD Assy Drawings | milestone | 0d | 2011-04-22 A | 2011-04-22 A |  | 100% |  |  |  |  |  | finish on 2011-04-22 |  |  |  | 22t | XN703106 | x | 0 | 0 | 934 | XNK | 31 | 200 | 200 | C | LND | KMD | X | N | XN05 | 3100 | N | 31 | X | SS | LND | 3100 |  |  |  |  |  |  |  |  |  |  |  |  |  |  |  |  |  |
| XN713101 |  | CA31 SiloStruc SK3101_01-05 - Steel Deliveries | milestone | 0d | 2011-06-30 A | 2011-06-30 A |  | 100% |  |  |  |  |  | finish on or after 2011-06-30 | TB26 - 3 - Construction Normal 7days * CA17 |  |  | 22t | XN713101 |  | 0 | 0 | 934 | XNK | 31 | 200 | 200 | C | LND | SD | X | N | XN06 | 3110 | N | 31 | X | SS | LND | 3110 |  |  |  |  |  |  |  |  |  |  |  |  |  |  |  |  |  |
| XN713105 |  | CA31 SiloStruc SK3105 - Steel Deliveries | milestone | 0d | 2011-06-30 A | 2011-06-30 A |  | 100% |  |  |  |  |  | finish on or after 2011-06-30 | TB26 - 3 - Construction Normal 7days * CA17 |  |  | 22t | XN713105 |  | 0 | 0 | 934 | XNK | 31 | 200 | 200 | C | LND | SD | X | N | XN06 | 3110 | N | 31 | X | SS | LND | 3110 |  |  |  |  |  |  |  |  |  |  |  |  |  |  |  |  |  |
| XN733101 |  | CA31 SiloStruc SK3101_06-13 - Steel Deliveries | milestone | 0d | 2011-06-30 A | 2011-06-30 A |  | 100% |  |  |  |  |  | finish on or after 2011-06-30 | TB26 - 3 - Construction Normal 7days * CA17 |  |  | 22t | XN733101 |  | 0 | 0 | 934 | XNK | 31 | 200 | 200 | C | LND | SD | X | N | XN06 | 3110 | N | 31 | X | SS | LND | 3110 |  |  |  |  |  |  |  |  |  |  |  |  |  |  |  |  |  |
| XN753101 |  | CA31 SiloStruc SK3101_30 - Steel Deliveries | milestone | 0d | 2011-07-15 A | 2011-07-15 A |  | 100% |  |  |  |  |  | finish on 2011-07-15 | TB26 - 3 - Construction Normal 7days * CA17 |  |  | 22t | XN753101 |  | 0 | 0 | 934 | XNK | 31 | 200 | 200 | C | LND | SD | X | N | XN06 | 3110 | N | 31 | X | SS | LND | 3110 |  |  |  |  |  |  |  |  |  |  |  |  |  |  |  |  |  |
| X0103120 |  | CA31 SiloStruc SK3101 Heavy Lift Availibility |  | 21d | 2011-07-30 A | 2011-08-23 A | XN203110 SS-2d | 100% |  |  |  |  |  |  |  |  |  | 785 | X0103120 |  | 40120 | 0 | 934 | ALL4 | 31 | 200 | 200 | C | LND |  | X | 0B | XN20 | 3110 | 0 | 31 | X | SS | LND | 3110 | E-04-21 | Silo | t | 27.8. | 2DC9000 |  |  |  |  |  |  |  |  |  |  |  |  |
| XN203110 |  | CA31 SiloStruc SK3101/05/06 - Erection Primary Steel/Roof |  | 78d | 2011-08-01 A | 2011-10-29 | XC40311020 FS-10d, XN703105, XN743101, XN713101 FS+10d, P3N012D (other project), P3N01S (other project) FF, P3N02YN (other project), XN753101 FS+10d, EN803110 (other project), XN733101 FS+10d, P3N02#N (other project) FF+10d, XN713105 FS+10d, XN703101, XN723101 |  | 55d |  |  | -158d | 0d |  |  | Piperacks, Main Structures [910 t]; Piperacks, Main structures [38675 h] | 19,304.98 | 38675,00 | XN203110 |  | 38675 | 0 | 934 | ALL4 | 31 | 200 | 200 | C | LND |  | X | N | XN20 | 3110 | N | 31 | X | SS | LND | 3110 | E-04-21 | Silo | t | 27.8. | 2DC9000 | 110908 | UDF_G4 | x | OMUS-1 | MTA |  |  |  |  |  |  |  |
| XC40311015_090 |  | CA31 SiloStruc - Structural Steel Module Installation (9) |  | 48d | 2011-08-03 A | 2011-09-27 | XC40311015_080 FS+3d |  | 27d |  |  | 457.5d |  |  |  |  |  | 650 | XC40311015_090 |  | 0 | 0 | 934 |  | 31 | 200 | 200 | C | MO04 | L4 | X | N | XC40 | 3110 | C | 31 | X | OB | LND | 3110 |  | Silo |  | 27.8. |  |  |  | x | OMUS-1 |  | 9 |  |  |  |  |  |  |
| XN713106 |  | CA31 SK3106 - Steel Deliveries | milestone | 0d | 2011-08-16 A | 2011-08-16 A |  | 100% |  |  |  |  |  | finish on 2011-08-15 | TB26 - 3 - Construction Normal 7days * CA17 |  |  | 22t | XN713106 |  | 0 | 0 | 934 | XNK | 31 | 200 | 200 | C | LND | SD | X | N | XN06 | 3100 | N | 31 | X | SS | LND | 3100 |  |  |  | 27.8. |  |  |  |  |  |  |  |  |  |  |  |  |  |
| XN403110 |  | CA31 SiloStruc SK3101/05 - Install Railings,Ladders,etc. |  | 46d | 2011-10-31 | 2011-12-23 | P3N02#N (other project), XN203110, EN803115 (other project) |  |  |  |  | -158d | 0d |  |  | Ladders & platforms [40 t]; Ladders & platforms [4000 h] | 672.57 | 4000,00 | XN403110 |  | 4000 | 0 | 934 | XNK | 31 | 200 | 200 | C | LND |  | X | N | XN40 | 3110 | N | 31 | X | SS | LND | 3110 |  | Check Roof - Cladding |  |  | 2DC9000 |  |  |  | OMUS-1 |  |  |  |  |  |  |  |  |
| XN603110 |  | CA31 SiloStruc SK3101/05 - Install Gratings |  | 46d | 2011-10-31 | 2011-12-23 | PN693115 (other project), XN403110 FF, PN693110 (other project) |  |  |  |  | -158d | 0d |  |  | Grating [1030 sqm]; Grating [3862.5 h] | 206.94 | 3862,50 | XN603110 |  | 3862,5 | 0 | 934 | XNK | 31 | 200 | 200 | C | LND |  | X | N | XN60 | 3110 | N | 31 | X | SS | LND | 3110 |  | Check Roof - Cladding |  |  | 2DC9000 |  |  |  | OMUS-1 |  |  |  |  |  |  |  |  |
| XN803110 |  | CA31 SiloStruc SK3101/05 - Install Cladding (North, East, West) |  | 60d | 2011-10-31 | 2012-01-16 | EN803110 (other project), EN803115 (other project), XN203110, P3N02YN (other project), P3N03N (other project) |  |  |  |  | -100d | 0d |  |  | Cladding [8025 sqm]; Cladding [40125 h] | 14,866.02 | 30093,75 | XN803110 |  | 40125 | 0 | 934 | ALL4 | 31 | 200 | 200 | C | LND |  | X | N | XN80 | 3110 | N | 31 | X | SS | LND | 3110 |  | Check Roof - Cladding |  |  | 2DC9000 |  |  |  | OMUS-1 |  |  |  |  |  |  |  |  |
| XN803110S |  | CA31 SiloStruc SK3101/05 - Install Cladding (Southern Wall) |  | 25d | 2011-10-31 | 2011-11-29 | P3N03N (other project), EN803115 (other project), XN203110, P3N02YN (other project), EN803110 (other project) |  |  |  |  | -65d | 0d |  |  | Cladding [2225 sqm]; Cladding [11125 h] | 14,866.02 | 8343,75 | XN803110S |  | 11125 | 0 | 934 | ALL4 | 31 | 200 | 200 | C | LND |  | X | N | XN80 | 3110 | N | 31 | X | SS | LND | 3110 |  | Check Roof - Cladding |  |  | 2DC9000 |  |  |  | OMUS-1 |  |  |  |  |  |  |  |  |
|  | H | **HVAC** |  |  | 2011-05-10 | 2012-07-30 |  |  |  |  |  |  |  |  |  |  |  |  |  |  |  |  |  |  |  |  |  |  |  |  |  |  |  |  |  |  |  |  |  |  |  |  |  |  |  |  |  |  |  |  |  |  |  |  |  |  |  |
| XH00311005 |  | CA31 SiloStruc - Installation HVAC (first part) |  | 170d | 2011-05-10 A | 2011-06-18 A | XH000000 SS, EH30311015 (other project), P3H01SQ (other project) FF+30d, EH30311005 (other project) | 100% |  | 2011-05-10 | 2011-11-25 |  |  | start on 2011-05-03 |  | HVAC - Warehouse CA31 [359 mhr]; HVAC - Warehouse CA31 [359 h] |  | 5485,00 | XH00311005 |  | 5485 | 359 | 934 | ALL4 | 31 | 200 | 200 | C | LND |  | X | H | XH00 | 3100 | H | 31 | X | hvac | LND | 3110 |  |  |  |  |  |  |  |  | ARMO |  |  | x | 2011-06-25 | 2011-09-30 | 2011-05-23 | 2011-08-17 | 31 |
| XH00311005_1 |  | CA31 SiloStruc - Installation HVAC (second part) |  | 110d | 2012-01-20 | 2012-05-31 | XC503110_1 FS+15d |  |  |  |  | 20d | 0d |  |  | HVAC - Warehouse CA31 [5126 mhr]; HVAC - Warehouse CA31 [5126 h] |  | 5485,00 | XH00311005 |  | 5485 | 359 | 934 | ALL4 | 31 | 200 | 200 | C | LND |  | X | H | XH00 | 3100 | H | 31 | X | hvac | LND | 3110 |  |  |  |  |  | REL XC50 |  |  | ARMO |  |  | 1 | 2011-06-25 | 2011-09-30 | 2011-05-23 | 2011-08-17 | 31 |
| XH00311007 |  | CA31 SiloStruc - HVAC ready for Heating | milestone | 0d | 2012-05-08 | 2012-05-08 | XH00311010 SS |  |  |  |  | 276.5d | 92.5d |  |  |  |  | 2194 | XH00311007 |  | 0 | 0 | 934 | ALL4 | 31 | 200 | 200 | C | LND |  | X | H | XH00 | 3110 | H | 31 | X | hvac | LND | 3110 |  |  |  |  |  |  |  |  | ARMO |  |  |  |  |  | 2011-07-25 | 2011-09-29 |  |
| XH00311010 |  | CA31 SiloStruc - Testing/Commissiong HVAC (Start w. temp. Power) |  | 70d | 2012-05-08 | 2012-07-30 | XH000C10, XH00311005 FS-20d, X0300008 FS+20d, X0300080, XH00311005_1 FS-20d |  |  |  |  | 22d | 0d |  |  |  |  |  | XH00311010 |  | 0 | 0 | 934 | ALL4 | 31 | 200 | 200 | C | LND |  | X | H | XH20 | 3110 | H | 31 | X | hvac | LND | 3110 |  |  |  |  |  |  |  |  | ARMO |  |  |  | 2011-09-20 | 2011-11-30 | 2011-07-25 | 2011-07-25 |  |

Notes:
- XN713100: Scope: 09.02.2011: weight: 25 ton
- XN713101: Scope: 09.02.2011: weight: 44 ton
- XN713105: Scope: 09.02.2011: weight: 458 ton
- XN733101: Scope: 09.02.2011: weight: 25 ton
- XN753101: Scope: 09.02.2011: weight: 458 ton / Current Status: 19.02.2011 (O.Siegel): 18-Feb-11 wurde nicht eingehalten / (erst 201 tonnen auf der Baustelle). Lieferverug ist nicht kritisch, da mit den / Arbeiten voraussichtlich in Juni 2011 begonnen werden kann.
- XN203110: Current Status: 20110719 (O.Siegel): das Dach wird in / 6 Segmenten (Frame und der Stahl dazwischen, also ohne Cladding) gefertigt.
- XN713106: Scope: 09.02.2011: weight: 25 ton
- XN403110: Current Status: 20110719 (O.Siegel): der Treppenhaus / (SK3105) wird im September beginnen mьsen und bis November 2011 fertig sein / mьssen.
- XN803110: Current Status: 2110806 Delivery end of September 2011 (Info from Fr. Schilka 02.08.2011)
- XN803110S: Current Status: 2110806 Delivery end of September 2011 (Info from Fr. Schilka 02.08.2011) / 110131 Installation of roof in warehouse (3102) not before completion of / cladding silo structure warehouse / ActID / Act Name / OD / ResID / BQ / Einheit / Aufteilung / XN803110 / CA31 SiloStruc SK3101/05 - Install / Cladding / 90 / MN0D / 8900 / sqm / LN0D / 44500 / h / NEW / XN803110 / CA31 SiloStruc SK3101/05 - Install Cladding (North, East, / West) / 65 / MN0D / 6675 / sqm / 75% / LN0D / 33375 / h / XN803110S / CA31 SiloStruc SK3101/05 - Install Cladding (Southern / Wall) / 30 / MN0D / 2225 / sqm / 25% / LN0D / 11125 / h
- XH00311005: Current Status: 28.04.2011 (O.Siegel): nach Rьcksprache mit C.Wendel wird in CA31 ab Level / +104 die Baufreiheit fьr ARMO erteilt.
- XH00311005_1: Current Status: 28.04.2011 (O.Siegel): nach Rьcksprache mit C.Wendel wird in CA31 ab Level / +104 die Baufreiheit fьr ARMO erteilt.
- XH00311010: Current Status: 21.01.2011 - Volkmann - Vorgдnger zur IBN HVAC Condensat, / LP-Dampf, Kьhlwasser von FF + 30 Tage Lag auf FS + 0 geдndert!

| ID | WBS | Activity | Type | Duration | Start | Finish | Predecessors | Complete | Remaining | Planned start | Planned finish | Total float | Free float | Constraint | Resources | Cost | Actual cost | TB26 Ressource Budget | UDF_SUPPLIER | UDF_SAVE ACT ID | UDF_BUDGETED LABOR UNIT | UDF_ACTUAL LABOR UNIT | Department | Type of Work | Constr. Area | Inquiry/Order No | PMT-Area | PMT-Schedule Org | PMT-Phase | PMT-Respons. | WBS Phase | WBS Discipline | WBS Type of Work | WBS Objects | Russia WBS Discipline (Russia) | Russia Construction Area | Russia WBS Phase | IMS | UPT | Russia WBS Objects | Subcontractor | UDF_CONTRACT START DATE | UDF_CONTRACT FINISH DATE | UDF_CONTRACT ITEM | UDF_CONTRACT INDICATOR | UDF_CHECK CRITICAL PATH | UDF_Vendor Representatives | UDF_SELECT UPDATE PROGRESS | UDF_CHECK RESOURCE DATES | MTA | UDF_SELECT | UDF_TB26 Sequence | Zeigen/n. Zeigen | Filter | WEIGHT | UDF_LEVEL | UDF_TAG No | UDF_Object No | UDF_PACKAGE | UDF_PO No | UDF_DELIVERY DATE PO | UDF_DELIVERY DATE DISPATCH PLANNED | UDF_DELIVERY DATE TO SITE PLANNED | UDF_DELIVERY DATE SITE NEED DATE | Comments | UDF_Weight (ton) | UDF_CONTRACT DATE PENALIZED | UDF_PENALIZED START | UDF_PENALIZED FINISH |
| --- | --- | --- | --- | --- | --- | --- | --- | --- | --- | --- | --- | --- | --- | --- | --- | --- | --- | --- | --- | --- | --- | --- | --- | --- | --- | --- | --- | --- | --- | --- | --- | --- | --- | --- | --- | --- | --- | --- | --- | --- | --- | --- | --- | --- | --- | --- | --- | --- | --- | --- | --- | --- | --- | --- | --- | --- | --- | --- | --- | --- | --- | --- | --- | --- | --- | --- | --- | --- | --- |
|  | U | **Package Units** |  |  |  |  |  |  |  |  |  |  |  |  |  |  |  |  |  |  |  |  |  |  |  |  |  |  |  |  |  |  |  |  |  |  |  |  |  |  |  |  |  |  |  |  |  |  |  |  |  |  |  |  |  |  |  |  |  |  |  |  |  |  |  |  |  |  |  |
|  | B | **Mechanical - Stationary Equipment** |  |  | 2010-08-24 | 2012-07-13 |  |  |  |  |  |  |  |  |  |  |  |  |  |  |  |  |  |  |  |  |  |  |  |  |  |  |  |  |  |  |  |  |  |  |  |  |  |  |  |  |  |  |  |  |  |  |  |  |  |  |  |  |  |  |  |  |  |  |  |  |  |  |  |
| XB50311005 |  | CA31 SiloStruc - Prefab Silos / Blenders |  | 59d | 2010-08-24 A | 2010-10-30 A | XB000C10 SS, P3ALL4S1 (other project), XB000C00 SS, P3B170 (other project), P3ALL4S2 (other project) FF+40d | 100% |  |  |  |  |  |  | Silos [2063 mhr]; Silos [2063 h] | 206,300 | 110,000 | 0,00 | Jansens & Dieperink | XB50311005 | 2053 | 2053 | 934 | ALL4 | 31 | 2DC9000 | 200 | 200 | C | LND | X | B | XB60 | 3100 | B | 31 | X | EQ | IMS | 3100 | OMUS-1 |  |  |  |  |  |  |  |  |  |  |  |  |  |  |  |  |  |  |  |  |  |  |  |  |  |  |  |  |
| XB50311010 |  | CA31 SiloStruc - Install Silos / Blenders |  | 8d | 2011-08-26 A | 2011-09-30 | F2870 FF, XN203110 SS, XB50311005, XB500C00 SS, ER293100 (other project) FS+40d, XB000C10 |  | 30d | 2011-08-26 | 2011-09-03 | -116d | 0d |  | Silos [687 mhr]; Silos [687 h] | 68,700 | 3,435 | 2750,00 | Jansens & Dieperink | XB50311010 | 697 | 0 | 934 | ALL4 | 31 | 2DC9000 | 200 | 200 | C | LND | X | B | XB60 | 3110 | B | 31 | X | EQ | LND | 3110 | OMUS-1 | 2011-02-20 | 2011-04-01 | E-08-01-03 | UDF_G4 | XB50311010 | 021 | 27.8. | x | MTA |  |  |  |  |  |  |  |  |  |  |  |  |  |  |  |  |  |  |  |
| XC40311015_100 |  | CA31 SiloStruc - Lift 1st Silo (10) | milestone | 0d | 2011-08-26 A | 2011-08-26 A | XC40311015_090 SS+1d | 100% |  |  |  |  |  | start on or after 2011-08-26 |  |  |  | 650 |  | XC40311015_100 | 0 | 0 | 934 |  | 31 |  | 200 | 200 | C | MO04 | X | B | XC40 | 3110 | C | 31 | X | OB | LND | 3110 | OMUS-1 |  |  |  |  | Silo |  | 27.8. |  |  | MTA | 10 | L4 |  |  |  |  |  |  |  |  |  |  |  |  |  |  |  |  |
| XC40311015_110 |  | CA31 SiloStruc - All silos installed (11) |  | 8d | 2011-08-26 A | 2011-09-30 | XC40311015_100, XB50311010 SS |  | 30d | 2011-08-26 | 2011-09-03 | 190d | 75.5d |  |  |  |  | 650 |  | XC40311015_110 | 0 | 0 | 934 |  | 31 |  | 200 | 200 | C | MO04 | X | B | XC40 | 3110 | C | 31 | X | OB | LND | 3110 | OMUS-1 |  |  |  |  | Silo |  | 27.8. |  |  |  | 11 | L4 |  |  |  |  |  |  |  |  |  |  |  |  |  |  |  |  |
| DV-21501-35 |  | DIVERTER VALVES |  | 4d | 2011-08-29 | 2011-09-01 |  |  |  |  |  | 215d | 133d | start on or after 2011-08-29 | Static Equipment < 10 tons [7.38 t]; Static equipment < 10t [738 h] | 29,520 |  | 738,00 |  | DV-21501-35 | 738 | 0 |  |  | 31 |  |  |  |  |  | X | B |  | 3110 |  |  |  |  |  |  | OMUS-1 |  |  |  |  |  |  |  |  |  |  |  | EQ | 1 | 960 | elev +43.00 | DV-21501-35 | SK3110 | PU10 CONVEYING SYSTEM (PK-21501) ZEPPELIN |  |  |  |  |  |  |  |  |  |  |
| DV-21540 |  | DIVERTER VALVES |  | 4d | 2011-08-29 | 2011-09-01 |  |  |  |  |  | 215d | 133d | start on or after 2011-08-29 | Static Equipment < 10 tons [0.2 t]; Static equipment < 10t [20.5 h] | 820 |  | 20,50 |  | DV-21540 | 20,5 | 0 |  |  | 31 |  |  |  |  |  | X | B |  | 3110 |  |  |  |  |  |  | OMUS-1 |  |  |  |  |  |  |  |  |  |  |  | EQ | 1 | 960 | elev +43.00 | DV-21540 | SK3110 | PU10 CONVEYING SYSTEM (PK-21501) ZEPPELIN |  |  |  |  |  |  |  |  |  |  |
| DV-22540 |  | DIVERTER VALVES |  | 4d | 2011-08-29 | 2011-09-01 |  |  |  |  |  | 215d | 133d | start on or after 2011-08-29 | Static Equipment < 10 tons [0.21 t]; Static equipment < 10t [20.5 h] | 840 |  | 20,50 |  | DV-22540 | 20,5 | 0 |  |  | 31 |  |  |  |  |  | X | B |  | 3110 |  |  |  |  |  |  | OMUS-1 |  |  |  |  |  |  |  |  |  |  |  | EQ | 1 | 960 | elev +37.00 | DV-22540 | SK3110 | PU10 CONVEYING SYSTEM (PK-21501) ZEPPELIN |  |  |  |  |  |  |  |  |  |  |
| HE-24101 |  | INSTRUMENT AIR HEATER (electrical) |  | 5d | 2011-08-29 | 2011-09-02 |  |  |  |  |  | 214d | 132d | start on or after 2011-08-29 | Static Equipment < 10 tons [0.1 t]; Static equipment < 10t [10 h] | 400 |  | 10,00 |  | HE-24101 | 10 | 0 |  |  | 31 |  |  |  |  |  | X | B |  | 3110 |  |  |  |  |  |  | OMUS-1 |  |  |  |  |  |  |  |  |  |  |  | EQ | 1 | 960 |  | HE-24101 | SK3110 | A06A NITROGEN / MINERAL OIL HEATER (ELECTRICAL) |  |  |  |  |  |  |  |  |  |  |
| HP-21501 |  | RECYCLE HOPPER |  | 5d | 2011-08-29 | 2011-09-02 |  |  |  |  |  | 214d | 132d | start on or after 2011-08-29 | Static Equipment < 10 tons [0.14 t]; Static equipment < 10t [14 h] | 560 |  | 14,00 |  | HP-21501 | 14 | 0 |  |  | 31 |  |  |  |  |  | X | B |  | 3110 |  |  |  |  |  |  | OMUS-1 |  |  |  |  |  |  |  |  |  |  |  | EQ | 1 | 960 |  | HP-21501 | SK3110 | PU10 CONVEYING SYSTEM (PK-21501) ZEPPELIN |  |  |  |  |  |  |  |  |  |  |
| MI-21503 |  | RECOVERED PELLETS SCALE |  | 4d | 2011-08-29 | 2011-09-01 |  |  |  |  |  | 215d | 133d | start on or after 2011-08-29 | Static Equipment < 10 tons [0.3 t]; Static equipment < 10t [30 h] | 1,200 |  | 30,00 | Haver & Boecker | MI-21503 | 30 | 0 |  |  | 31 |  |  |  |  |  | X | B |  | 3110 |  |  |  |  |  |  | OMUS-1 |  |  |  |  |  | 022 |  |  |  |  |  | EQ | 1 | 10000 | concrete +0.00 | MI-21503 | SK3110 | A13 SCALES (MI-21-/22104/6A) | 2 DC 9010 | 2011-01-25 | 2011-02-25 | 2011-04-05 | 2011-06-20 |  |  |  |  |  |
| MI-31201 |  | BAG CHECK SCALE |  | 4d | 2011-08-29 | 2011-09-01 |  |  |  |  |  | 215d | 133d | start on or after 2011-08-29 | Static Equipment < 10 tons [0.1 t]; Static equipment < 10t [10 h] | 400 |  | 10,00 | Haver & Boecker | MI-31201 | 10 | 0 |  |  | 31 |  |  |  |  |  | X | B |  | 3110 |  |  |  |  |  |  | OMUS-1 |  |  |  |  |  | 022 |  |  |  |  |  | EQ | 1 | 10000 | concrete +10.65 | MI-31201 | SK3110 | A13 SCALES (MI-21-/22104/6A) | 2 DC 9010 | 2011-01-25 | 2011-02-25 | 2011-04-05 | 2011-06-20 |  |  |  |  |  |
| PK-21503 |  | BLENDER VENT COLLECTION SYSTEM |  | 10d | 2011-08-29 | 2011-09-08 |  |  |  |  |  | 209d | 127d | start on or after 2011-08-29 | Static Equipment < 10 tons [10.89 t]; Static equipment < 10t [83.94 h] | 43,556 |  | 0,00 |  | PK-21503 | 0 | 0 |  |  | 31 |  |  |  |  |  | X | B |  | 3110 |  |  |  |  |  |  | OMUS-1 |  |  |  |  |  |  |  |  |  |  |  | EQ | 1 | 960 |  | PK-21503 | SK3110 | PU10 CONVEYING SYSTEM (PK-21501) ZEPPELIN |  |  |  |  |  |  |  |  |  |  |
| RF-21501A/B/C |  | PELLET BLENDER OUTLET FEEDERS |  | 13.25d | 2011-08-29 | 2011-09-13 | XM000C00 |  |  |  |  | 205.75d | 123.75d | start on or after 2011-08-29 | Static Equipment < 10 tons [2.88 t]; Static equipment < 10t [288 h] | 11,520 |  | 288,00 |  | RF-21501A/B/C | 288 | 0 |  |  | 31 |  |  |  |  |  | X | B |  | 3110 |  |  |  |  |  |  | OMUS-1 |  |  |  |  |  |  |  |  |  |  |  | EQ | 1 | 960 | elev +14.15 | RF-21501A/B/C | SK3110 | PU10 CONVEYING SYSTEM (PK-21501) ZEPPELIN |  |  |  |  |  |  |  |  |  |  |
| RF-21502 |  | ELUTRIATOR OUTLET ROTARY VALVE |  | 3d | 2011-08-29 | 2011-08-31 | XM000C00 |  |  |  |  | 216d | 134d | start on or after 2011-08-29 | Static Equipment < 10 tons [1.45 t]; Static equipment < 10t [145.2 h] | 5,808 |  | 145,20 |  | RF-21502 | 145,2 | 0 |  |  | 31 |  |  |  |  |  | X | B |  | 3110 |  |  |  |  |  |  | OMUS-1 |  |  |  |  |  |  |  |  |  |  |  | EQ | 1 | 1452 | elev +18.15 | RF-21502 | SK3110 | PU10 CONVEYING SYSTEM (PK-21501) ZEPPELIN |  |  |  |  |  |  |  |  |  |  |
| RF-21503 |  | SCREW CONVEYER |  | 5d | 2011-08-29 | 2011-09-02 |  |  |  |  |  | 214d | 132d | start on or after 2011-08-29 | Static Equipment < 10 tons [0.12 t]; Static equipment < 10t [11.5 h] | 460 |  | 11,50 |  | RF-21503 | 11,5 | 0 |  |  | 31 |  |  |  |  |  | X | B |  | 3110 |  |  |  |  |  |  | OMUS-1 |  |  |  |  |  |  |  |  |  |  |  | EQ | 1 | 1452 | concrete +9.0 | RF-21503 | SK3110 | PU10 CONVEYING SYSTEM (PK-21501) ZEPPELIN |  |  |  |  |  | Install Heat Tracing ET60 |  |  |  |  |
| RF-21504 |  | OUTLET ROTARY VALVE (part of PK21503) |  | 3d | 2011-08-29 | 2011-08-31 |  |  |  |  |  | 216d | 134d | start on or after 2011-08-29 | Static equipment < 10t [18 h]; Static Equipment < 10 tons [0.18 t] | 720 |  | 18,00 |  | RF-21504 | 18 | 0 |  |  | 31 |  |  |  |  |  | X | B |  | 3110 |  |  |  |  |  |  | OMUS-1 |  |  |  |  |  |  |  |  |  |  |  | EQ | 1 | 960 |  | RF-21504 | SK3110 | PU10 CONVEYING SYSTEM (PK-21501) ZEPPELIN |  |  |  |  |  |  |  |  |  |  |
| RF-21505-14 |  | ROTARY FEEDER |  | 45.75d | 2011-08-29 | 2011-10-20 | XM000C00 |  |  |  |  | 173.25d | 91.25d | start on or after 2011-08-29 | Static Equipment < 10 tons [5.4 t]; Static equipment < 10t [540 h] | 21,600 |  | 540,00 |  | RF-21505-14 | 540 | 0 |  |  | 31 |  |  |  |  |  | X | B |  | 3110 |  |  |  |  |  |  | OMUS-1 |  |  |  |  |  |  |  |  |  |  |  | EQ | 1 | 540 | elev +6.15 | RF-21505-14 | SK3110 | PU10 CONVEYING SYSTEM (PK-21501) ZEPPELIN |  |  |  |  |  |  |  |  |  |  |
| RF-21517 |  | ROTARY FEEDER |  | 5d | 2011-08-29 | 2011-09-02 |  |  |  |  |  | 214d | 132d | start on or after 2011-08-29 | Static Equipment < 10 tons [0.2 t]; Static equipment < 10t [20 h] | 800 |  | 20,00 |  | RF-21517 | 20 | 0 |  |  | 31 |  |  |  |  |  | X | B |  | 3110 |  |  |  |  |  |  | OMUS-1 |  |  |  |  |  |  |  |  |  |  |  | EQ | 1 | 1452 | elev +0.35 | RF-21517 | SK3110 | PU10 CONVEYING SYSTEM (PK-21501) ZEPPELIN |  |  |  |  |  |  |  |  |  |  |
| RF-22501A/B/C |  | ROTARY FEEDERS |  | 8.25d | 2011-08-29 | 2011-09-07 | XM000C00 |  |  |  |  | 210.75d | 128.75d | start on or after 2011-08-29 | Static Equipment < 10 tons [2.88 t]; Static equipment < 10t [288 h] | 11,520 |  | 288,00 |  | RF-22501A/B/C | 288 | 0 |  |  | 31 |  |  |  |  |  | X | B |  | 3110 |  |  |  |  |  |  | OMUS-1 |  |  |  |  |  |  |  |  |  |  |  | EQ | 1 | 960 | elev +14.15 | RF-22501A/B/C | SK3110 | PU10 CONVEYING SYSTEM (PK-21501) ZEPPELIN |  |  |  |  |  |  |  |  |  |  |
| RF-22502 |  | ELUTRIATOR OUTLET ROTARY VALVE |  | 5d | 2011-08-29 | 2011-09-02 | XM000C00 |  |  |  |  | 214d | 132d | start on or after 2011-08-29 | Static Equipment < 10 tons [1.45 t]; Static equipment < 10t [145.2 h] | 5,808 |  | 145,20 |  | RF-22502 | 145,2 | 0 |  |  | 31 |  |  |  |  |  | X | B |  | 3110 |  |  |  |  |  |  | OMUS-1 |  |  |  |  |  |  |  |  |  |  |  | EQ | 1 | 1452 | elev +14.15 | RF-22502 | SK3110 | PU10 CONVEYING SYSTEM (PK-21501) ZEPPELIN |  |  |  |  |  |  |  |  |  |  |
| RF-22504 |  | OUTLET ROTARY VALVE (part of PK21503) |  | 4d | 2011-08-29 | 2011-09-01 |  |  |  |  |  | 215d | 133d | start on or after 2011-08-29 | Static Equipment < 10 tons [0.18 t]; Static equipment < 10t [18 h] | 720 |  | 36,00 |  | RF-22504 | 18 | 0 |  |  | 31 |  |  |  |  |  | X | B |  | 3110 |  |  |  |  |  |  | OMUS-1 |  |  |  |  |  |  |  |  |  |  |  | EQ | 1 | 960 |  | RF-22504 | SK3110 | PU10 CONVEYING SYSTEM (PK-21501) ZEPPELIN |  |  |  |  |  |  |  |  |  |  |
| V-21504 A/B/C |  | TRANSFER AIR LIQUID SEPARATOR |  | 5d | 2011-08-29 | 2011-09-02 |  |  |  |  |  | 214d | 132d | start on or after 2011-08-29 | Static Equipment < 10 tons [0.86 t]; Static equipment < 10t [85.5 h] | 3,440 |  | 85,50 |  | V-21504 A/B/C | 85,5 | 0 |  |  | 31 |  |  |  |  |  | X | B |  | 3110 |  |  |  |  |  |  | OMUS-1 |  |  |  |  |  |  |  |  |  |  |  | EQ | 1 | 1350 | structure +0.15 | V-21504 A/B/C | SK3110 | PU10 CONVEYING SYSTEM (PK-21501) ZEPPELIN |  |  |  |  |  |  |  |  |  |  |
| XX-21501-F01 |  | ELUTRIATOR EXHAUST AIR CYCLONE |  | 0d | 2011-08-29 | 2011-08-29 |  |  |  |  |  | 201.5d | 0d | start on or after 2011-08-29 | Static Equipment < 10 tons [1.35 t]; Static equipment < 10t [135 h] | 5,400 |  | 135,00 |  | XX-21501-F01 | 135 | 0 |  |  | 31 |  |  |  |  |  | X | B |  | 3110 |  |  |  |  |  |  | OMUS-1 |  |  |  |  |  |  |  |  |  |  |  | EQ | 1 | 1350 | structure +22.61 | XX-21501-F01 | SK3110 | PU10 CONVEYING SYSTEM (PK-21501) ZEPPELIN |  |  |  |  |  |  |  |  |  |  |
| XX-22501 |  | ELUTRIATOR (Pellet cleaning and Dedusting System) |  | 0d | 2011-08-29 | 2011-08-29 | XX-21501-F01 |  |  |  |  | 201.5d | 0d | start on or after 2011-08-29 | Static Equipment < 10 tons [1.35 t]; Static equipment < 10t [135 h] | 5,400 |  | 135,00 |  | XX-22501 | 135 | 0 |  |  | 31 |  |  |  |  |  | X | B |  | 3110 |  |  |  |  |  |  | OMUS-1 |  |  |  |  |  |  |  |  |  |  |  | EQ | 1 | 1350 | structure +36.41 | XX-22501 | SK3110 | PU10 CONVEYING SYSTEM (PK-21501) ZEPPELIN |  |  |  |  |  |  |  |  |  |  |
| XX-22501-F01 |  | ELUTRIATOR EXHAUST AIR CYCLONE |  | 17.5d | 2011-08-29 | 2011-09-17 | XX-22501 |  |  |  |  | 201.5d | 119.5d | start on or after 2011-08-29 | Static Equipment < 10 tons [1.35 t]; Static equipment < 10t [135 h] | 5,400 |  | 135,00 |  | XX-22501-F01 | 135 | 0 |  |  | 31 |  |  |  |  |  | X | B |  | 3110 |  |  |  |  |  |  | OMUS-1 |  |  |  |  |  |  |  |  |  |  |  | EQ |  | 1350 | structure +37.61 | XX-22501-F01 | SK3110 | PU10 CONVEYING SYSTEM (PK-21501) ZEPPELIN |  |  |  |  |  |  |  |  |  |  |
| HO-30301 |  | SUSPENSION CRANE |  | 3.75d | 2011-09-26 | 2011-09-29 | HO-30317 SS, XM000C00 |  |  |  |  | 191.25d | 109.25d |  | Static Equipment < 10 tons [0.3 t]; Static equipment < 10t [30 h] | 1,200 |  | 30,00 |  | HO-30301 | 30 | 0 |  |  | 31 |  |  |  |  |  | X | B |  | 3110 |  |  |  |  |  |  | OMUS-1 |  |  |  |  |  |  |  |  |  |  |  | EQ |  | 1270 |  | HO-30301 | SK3110 | A12 OVERHEAD CRANES / TROLLEYS (incl. in Civil Subcontract) |  |  | 2011-01-09 |  | 2011-02-01 |  |  |  |  |  |
| HO-30316 |  | SUSPENSION CRANE |  | 16.25d | 2011-09-26 | 2011-10-14 | P3A12S2 (other project), XM000C00 |  |  |  |  | 178.75d | 96.75d |  | Static Equipment < 10 tons [1.27 t]; Static equipment < 10t [127 h] | 5,080 |  | 127,00 |  | HO-30316 | 127 | 0 |  |  | 31 |  |  |  |  |  | X | B |  | 3110 |  |  |  |  |  |  | OMUS-1 |  |  |  |  |  |  |  |  |  |  |  | EQ |  | 1270 |  | HO-30316 | SK3110 | A12 OVERHEAD CRANES / TROLLEYS (incl. in Civil Subcontract) |  |  | 2011-01-09 |  | 2011-02-01 |  |  |  |  |  |
| HO-30317 |  | SUSPENSION CRANE |  | 16.25d | 2011-09-26 | 2011-10-14 | P3A12S2 (other project), XM000C00 |  |  |  |  | 178.75d | 0d |  | Static Equipment < 10 tons [1.27 t]; Static equipment < 10t [127 h] | 5,080 |  | 127,00 |  | HO-30317 | 127 | 0 |  |  | 31 |  |  |  |  |  | X | B |  | 3110 |  |  |  |  |  |  | OMUS-1 |  |  |  |  |  |  |  |  |  |  |  | EQ |  | 1270 |  | HO-30317 | SK3110 | A12 OVERHEAD CRANES / TROLLEYS (incl. in Civil Subcontract) |  |  | 2011-01-09 |  | 2011-02-01 |  |  |  |  |  |
| HO-30302 |  | MANUAL TROLLEY HAND GREATED |  | 3.75d | 2011-10-01 | 2011-10-05 | XB50311010 |  |  |  |  | 186.25d | 104.25d |  | Static Equipment < 10 tons [0.3 t]; Static equipment < 10t [30 h] | 1,200 |  | 30,00 |  | HO-30302 | 30 | 0 |  |  | 31 |  |  |  |  |  | X | B |  | 3110 |  |  |  |  |  |  | OMUS-1 |  |  |  |  |  |  | 27.8. |  |  |  |  | EQ |  | 1270 |  | HO-30302 | SK3110 | A12 OVERHEAD CRANES / TROLLEYS (incl. in Civil Subcontract) |  |  | 2011-01-09 |  | 2011-02-01 |  |  |  |  |  |
| HO-30303 |  | MANUAL TROLLEY HAND GREATED |  | 3.75d | 2011-10-01 | 2011-10-05 | XB50311010 |  |  |  |  | 186.25d | 104.25d |  | Static Equipment < 10 tons [0.3 t]; Static equipment < 10t [30 h] | 1,200 |  | 30,00 |  | HO-30303 | 30 | 0 |  |  | 31 |  |  |  |  |  | X | B |  | 3110 |  |  |  |  |  |  | OMUS-1 |  |  |  |  |  |  | 27.8. |  |  |  |  | EQ |  | 1270 |  | HO-30303 | SK3110 | A12 OVERHEAD CRANES / TROLLEYS (incl. in Civil Subcontract) |  |  | 2011-01-09 |  | 2011-02-01 |  |  |  |  |  |
| HO-30304 |  | MANUAL TROLLEY HAND GREATED |  | 3.75d | 2011-10-01 | 2011-10-05 | XB50311010 |  |  |  |  | 186.25d | 104.25d |  | Static Equipment < 10 tons [0.3 t]; Static equipment < 10t [30 h] | 1,200 |  | 30,00 |  | HO-30304 | 30 | 0 |  |  | 31 |  |  |  |  |  | X | B |  | 3110 |  |  |  |  |  |  | OMUS-1 |  |  |  |  |  |  | 27.8. |  |  |  |  | EQ |  | 1270 |  | HO-30304 | SK3110 | A12 OVERHEAD CRANES / TROLLEYS (incl. in Civil Subcontract) |  |  | 2011-01-09 |  | 2011-02-01 |  |  |  |  |  |
| HO-30305 |  | MANUAL TROLLEY HAND GREATED |  | 3.75d | 2011-10-01 | 2011-10-05 | XB50311010 |  |  |  |  | 186.25d | 104.25d |  | Static Equipment < 10 tons [0.3 t]; Static equipment < 10t [30 h] | 1,200 |  | 30,00 |  | HO-30305 | 30 | 0 |  |  | 31 |  |  |  |  |  | X | B |  | 3110 |  |  |  |  |  |  | OMUS-1 |  |  |  |  |  |  | 27.8. |  |  |  |  | EQ |  | 1270 |  | HO-30305 | SK3110 | A12 OVERHEAD CRANES / TROLLEYS (incl. in Civil Subcontract) |  |  | 2011-01-09 |  | 2011-02-01 |  |  |  |  |  |
| HO-30306 |  | MANUAL TROLLEY HAND GREATED |  | 3.75d | 2011-10-01 | 2011-10-05 | XB50311010 |  |  |  |  | 186.25d | 104.25d |  | Static Equipment < 10 tons [0.3 t]; Static equipment < 10t [30 h] | 1,200 |  | 30,00 |  | HO-30306 | 30 | 0 |  |  | 31 |  |  |  |  |  | X | B |  | 3110 |  |  |  |  |  |  | OMUS-1 |  |  |  |  |  |  | 27.8. |  |  |  |  | EQ |  | 1270 |  | HO-30306 | SK3110 | A12 OVERHEAD CRANES / TROLLEYS (incl. in Civil Subcontract) |  |  | 2011-01-09 |  | 2011-02-01 |  |  |  |  |  |
| HO-30307 |  | MANUAL TROLLEY HAND GREATED |  | 3.75d | 2011-10-01 | 2011-10-05 | XB50311010 |  |  |  |  | 186.25d | 104.25d |  | Static Equipment < 10 tons [0.3 t]; Static equipment < 10t [30 h] | 1,200 |  | 30,00 |  | HO-30307 | 30 | 0 |  |  | 31 |  |  |  |  |  | X | B |  | 3110 |  |  |  |  |  |  | OMUS-1 |  |  |  |  |  |  | 27.8. |  |  |  |  | EQ |  | 1270 |  | HO-30307 | SK3110 | A12 OVERHEAD CRANES / TROLLEYS (incl. in Civil Subcontract) |  |  | 2011-01-09 |  | 2011-02-01 |  |  |  |  |  |
| HO-30308 |  | MANUAL TROLLEY HAND GREATED |  | 3.75d | 2011-10-01 | 2011-10-05 | XB50311010 |  |  |  |  | 186.25d | 104.25d |  | Static Equipment < 10 tons [0.3 t]; Static equipment < 10t [30 h] | 1,200 |  | 30,00 |  | HO-30308 | 30 | 0 |  |  | 31 |  |  |  |  |  | X | B |  | 3110 |  |  |  |  |  |  | OMUS-1 |  |  |  |  |  |  | 27.8. |  |  |  |  | EQ |  | 1270 |  | HO-30308 | SK3110 | A12 OVERHEAD CRANES / TROLLEYS (incl. in Civil Subcontract) |  |  | 2011-01-09 |  | 2011-02-01 |  |  |  |  |  |
| HO-30309 |  | DAVIT |  | 3.75d | 2011-10-01 | 2011-10-05 | XB50311010 |  |  |  |  | 186.25d | 104.25d |  | Static Equipment < 10 tons [0.3 t]; Static equipment < 10t [30 h] | 1,200 |  | 30,00 |  | HO-30309 | 30 | 0 |  |  | 31 |  |  |  |  |  | X | B |  | 3110 |  |  |  |  |  |  | OMUS-1 |  |  |  |  |  |  | 27.8. |  |  |  |  | EQ |  | 1270 |  | HO-30309 | SK3110 | A12 OVERHEAD CRANES / TROLLEYS (incl. in Civil Subcontract) |  |  | 2011-01-09 |  | 2011-02-01 |  |  |  |  |  |
| HO-30310 |  | DAVIT |  | 3.75d | 2011-10-01 | 2011-10-05 | XB50311010 |  |  |  |  | 186.25d | 104.25d |  | Static Equipment < 10 tons [0.3 t]; Static equipment < 10t [30 h] | 1,200 |  | 30,00 |  | HO-30310 | 30 | 0 |  |  | 31 |  |  |  |  |  | X | B |  | 3110 |  |  |  |  |  |  | OMUS-1 |  |  |  |  |  |  | 27.8. |  |  |  |  | EQ |  | 1270 |  | HO-30310 | SK3110 | A12 OVERHEAD CRANES / TROLLEYS (incl. in Civil Subcontract) |  |  | 2011-01-09 |  | 2011-02-01 |  |  |  |  |  |
| HO-30311 |  | DAVIT |  | 3.75d | 2011-10-01 | 2011-10-05 | XB50311010 |  |  |  |  | 186.25d | 104.25d |  | Static Equipment < 10 tons [0.3 t]; Static equipment < 10t [30 h] | 1,200 |  | 30,00 |  | HO-30311 | 30 | 0 |  |  | 31 |  |  |  |  |  | X | B |  | 3110 |  |  |  |  |  |  | OMUS-1 |  |  |  |  |  |  | 27.8. |  |  |  |  | EQ |  | 1270 |  | HO-30311 | SK3110 | A12 OVERHEAD CRANES / TROLLEYS (incl. in Civil Subcontract) |  |  | 2011-01-09 |  | 2011-02-01 |  |  |  |  |  |
| HO-30312 |  | DAVIT |  | 3.75d | 2011-10-01 | 2011-10-05 | XB50311010 |  |  |  |  | 186.25d | 104.25d |  | Static Equipment < 10 tons [0.3 t]; Static equipment < 10t [30 h] | 1,200 |  | 30,00 |  | HO-30312 | 30 | 0 |  |  | 31 |  |  |  |  |  | X | B |  | 3110 |  |  |  |  |  |  | OMUS-1 |  |  |  |  |  |  | 27.8. |  |  |  |  | EQ |  | 1270 |  | HO-30312 | SK3110 | A12 OVERHEAD CRANES / TROLLEYS (incl. in Civil Subcontract) |  |  | 2011-01-09 |  | 2011-02-01 |  |  |  |  |  |
| HO-30313 |  | DAVIT |  | 3.75d | 2011-10-01 | 2011-10-05 | XB50311010 |  |  |  |  | 186.25d | 104.25d |  | Static Equipment < 10 tons [0.3 t]; Static equipment < 10t [30 h] | 1,200 |  | 30,00 |  | HO-30313 | 30 | 0 |  |  | 31 |  |  |  |  |  | X | B |  | 3110 |  |  |  |  |  |  | OMUS-1 |  |  |  |  |  |  | 27.8. |  |  |  |  | EQ |  | 1270 |  | HO-30313 | SK3110 | A12 OVERHEAD CRANES / TROLLEYS (incl. in Civil Subcontract) |  |  | 2011-01-09 |  | 2011-02-01 |  |  |  |  |  |
| HO-30314 |  | DAVIT |  | 3.75d | 2011-10-01 | 2011-10-05 | XB50311010 |  |  |  |  | 186.25d | 104.25d |  | Static Equipment < 10 tons [0.3 t]; Static equipment < 10t [30 h] | 1,200 |  | 30,00 |  | HO-30314 | 30 | 0 |  |  | 31 |  |  |  |  |  | X | B |  | 3110 |  |  |  |  |  |  | OMUS-1 |  |  |  |  |  |  | 27.8. |  |  |  |  | EQ |  | 1270 |  | HO-30314 | SK3110 | A12 OVERHEAD CRANES / TROLLEYS (incl. in Civil Subcontract) |  |  | 2011-01-09 |  | 2011-02-01 |  |  |  |  |  |
| HO-30315 |  | TROLLEY ELECTRICAL |  | 3.75d | 2011-10-01 | 2011-10-05 | XB50311010 |  |  |  |  | 186.25d | 104.25d |  | Static Equipment < 10 tons [0.3 t]; Static equipment < 10t [30 h] | 1,200 |  | 30,00 |  | HO-30315 | 30 | 0 |  |  | 31 |  |  |  |  |  | X | B |  | 3110 |  |  |  |  |  |  | OMUS-1 |  |  |  |  |  |  | 27.8. |  |  |  |  | EQ |  | 1270 |  | HO-30315 | SK3110 | A12 OVERHEAD CRANES / TROLLEYS (incl. in Civil Subcontract) |  |  | 2011-01-09 |  | 2011-02-01 |  |  |  |  |  |
| HO-30318 |  | TROLLEY ELECTRICAL |  | 3.75d | 2011-10-01 | 2011-10-05 | XB50311010 |  |  |  |  | 186.25d | 104.25d |  | Static Equipment < 10 tons [0.3 t]; Static equipment < 10t [30 h] | 1,200 |  | 30,00 |  | HO-30318 | 30 | 0 |  |  | 31 |  |  |  |  |  | X | B |  | 3110 |  |  |  |  |  |  | OMUS-1 |  |  |  |  |  |  | 27.8. |  |  |  |  | EQ |  | 1270 |  | HO-30318 | SK3110 | A12 OVERHEAD CRANES / TROLLEYS (incl. in Civil Subcontract) |  |  | 2011-01-09 |  | 2011-02-01 |  |  |  |  |  |
| HO-30319 |  | TROLLEY ELECTRICAL |  | 3.75d | 2011-10-01 | 2011-10-05 | XB50311010 |  |  |  |  | 186.25d | 104.25d |  | Static Equipment < 10 tons [0.3 t]; Static equipment < 10t [30 h] | 1,200 |  | 30,00 |  | HO-30319 | 30 | 0 |  |  | 31 |  |  |  |  |  | X | B |  | 3110 |  |  |  |  |  |  | OMUS-1 |  |  |  |  |  |  | 27.8. |  |  |  |  | EQ |  | 1270 |  | HO-30319 | SK3110 | A12 OVERHEAD CRANES / TROLLEYS (incl. in Civil Subcontract) |  |  | 2011-01-09 |  | 2011-02-01 |  |  |  |  |  |
| HO-30320 |  | TROLLEY ELECTRICAL |  | 3.75d | 2011-10-01 | 2011-10-05 | XB50311010 |  |  |  |  | 186.25d | 104.25d |  | Static Equipment < 10 tons [0.3 t]; Static equipment < 10t [30 h] | 1,200 |  | 30,00 |  | HO-30320 | 30 | 0 |  |  | 31 |  |  |  |  |  | X | B |  | 3110 |  |  |  |  |  |  | OMUS-1 |  |  |  |  |  |  | 27.8. |  |  |  |  | EQ |  | 1270 |  | HO-30320 | SK3110 | A12 OVERHEAD CRANES / TROLLEYS (incl. in Civil Subcontract) |  |  | 2011-01-09 |  | 2011-02-01 |  |  |  |  |  |
| HO-30321 |  | MANUAL TROLLEY HAND GREATED |  | 3.75d | 2011-10-01 | 2011-10-05 | XB50311010 |  |  |  |  | 186.25d | 104.25d |  | Static Equipment < 10 tons [0.3 t]; Static equipment < 10t [30 h] | 1,200 |  | 30,00 |  | HO-30321 | 30 | 0 |  |  | 31 |  |  |  |  |  | X | B |  | 3110 |  |  |  |  |  |  | OMUS-1 |  |  |  |  |  |  | 27.8. |  |  |  |  | EQ |  | 1270 |  | HO-30321 | SK3110 | A12 OVERHEAD CRANES / TROLLEYS (incl. in Civil Subcontract) |  |  | 2011-01-09 |  | 2011-02-01 |  |  |  |  |  |
| HO-30322 |  | MANUAL TROLLEY HAND GREATED |  | 3.75d | 2011-10-01 | 2011-10-05 | XB50311010 |  |  |  |  | 186.25d | 104.25d |  | Static Equipment < 10 tons [0.3 t]; Static equipment < 10t [30 h] | 1,200 |  | 30,00 |  | HO-30322 | 30 | 0 |  |  | 31 |  |  |  |  |  | X | B |  | 3110 |  |  |  |  |  |  | OMUS-1 |  |  |  |  |  |  | 27.8. |  |  |  |  | EQ |  | 1270 |  | HO-30322 | SK3110 | A12 OVERHEAD CRANES / TROLLEYS (incl. in Civil Subcontract) |  |  | 2011-01-09 |  | 2011-02-01 |  |  |  |  |  |
| HO-30323 |  | MANUAL TROLLEY HAND GREATED |  | 3.75d | 2011-10-01 | 2011-10-05 | XB50311010 |  |  |  |  | 186.25d | 104.25d |  | Static Equipment < 10 tons [0.3 t]; Static equipment < 10t [30 h] | 1,200 |  | 30,00 |  | HO-30323 | 30 | 0 |  |  | 31 |  |  |  |  |  | X | B |  | 3110 |  |  |  |  |  |  | OMUS-1 |  |  |  |  |  |  | 27.8. |  |  |  |  | EQ |  | 1270 |  | HO-30323 | SK3110 | A12 OVERHEAD CRANES / TROLLEYS (incl. in Civil Subcontract) |  |  | 2011-01-09 |  | 2011-02-01 |  |  |  |  |  |
| HO-30324 |  | MANUAL TROLLEY HAND GREATED |  | 3.75d | 2011-10-01 | 2011-10-05 | XB50311010 |  |  |  |  | 186.25d | 104.25d |  | Static Equipment < 10 tons [0.3 t]; Static equipment < 10t [30 h] | 1,200 |  | 30,00 |  | HO-30324 | 30 | 0 |  |  | 31 |  |  |  |  |  | X | B |  | 3110 |  |  |  |  |  |  | OMUS-1 |  |  |  |  |  |  | 27.8. |  |  |  |  | EQ |  | 1270 |  | HO-30324 | SK3110 | A12 OVERHEAD CRANES / TROLLEYS (incl. in Civil Subcontract) |  |  | 2011-01-09 |  | 2011-02-01 |  |  |  |  |  |
| HO-30325 |  | MANUAL TROLLEY HAND GREATED |  | 3.75d | 2011-10-01 | 2011-10-05 | XB50311010 |  |  |  |  | 186.25d | 104.25d |  | Static Equipment < 10 tons [0.3 t]; Static equipment < 10t [30 h] | 1,200 |  | 30,00 |  | HO-30325 | 30 | 0 |  |  | 31 |  |  |  |  |  | X | B |  | 3110 |  |  |  |  |  |  | OMUS-1 |  |  |  |  |  |  | 27.8. |  |  |  |  | EQ |  | 1270 |  | HO-30325 | SK3110 | A12 OVERHEAD CRANES / TROLLEYS (incl. in Civil Subcontract) |  |  | 2011-01-09 |  | 2011-02-01 |  |  |  |  |  |
| BG-31201 A/B |  | FFS BAGGING MACHINE |  | 12.5d | 2011-12-15 | 2011-12-29 | XM003110 SS |  |  |  |  | -2.5d | 0d |  | Static Equipment < 10 tons; Static equipment < 10t |  |  | 0,00 |  | BG-31201 A/B | 0 | 0 |  |  | 31 |  |  |  |  |  | X | B |  | 3110 |  |  |  |  |  |  | OMUS-1 |  |  |  |  |  |  |  |  |  |  |  | EQ |  | 10000 |  | BG-31201 A/B | SK3110 | PU06 BAGGING SYSTEM (PK-31201A/B) |  | 2011-01-25 | 2011-02-25 | 2011-04-05 | 2011-06-20 |  |  |  |  |  |
| BL-31201A/B |  | DEDUSTING BLOWER |  | 12.5d | 2011-12-15 | 2011-12-29 | XM000C00, XM003110 SS |  |  |  |  | 114.5d | 32.5d |  | Static Equipment < 10 tons [1 t]; Static equipment < 10t [100 h] | 4,000 |  | 100,00 |  | BL-31201A/B | 100 | 0 |  |  | 31 |  |  |  |  |  | X | B |  | 3110 |  |  |  |  |  |  | OMUS-1 |  |  |  |  |  |  |  |  |  |  |  | EQ |  | 1000 | concrete +10.65 | BL-31201A/B | SK3110 | PU06 BAGGING SYSTEM (PK-31201A/B) |  |  |  |  |  |  |  |  |  |  |
| F-31201A/B |  | DEDUSTING FILTER SYSTEM |  | 12.5d | 2011-12-15 | 2011-12-29 | XM000C00, XM003110 SS |  |  |  |  | 114.5d | 32.5d |  | Static Equipment < 10 tons [1 t]; Static equipment < 10t [100 h] | 4,000 |  | 100,00 |  | F-31201A/B | 100 | 0 |  |  | 31 |  |  |  |  |  | X | B |  | 3110 |  |  |  |  |  |  | OMUS-1 |  |  |  |  |  |  |  |  |  |  |  | EQ |  | 500 | concrete +10.650 | F-31201A/B | SK3110 | PU06 BAGGING SYSTEM (PK-31201A/B) |  |  |  |  |  |  |  |  |  |  |
| MI-21501 |  | TRUCK LOADING SCALE |  | 15d | 2011-12-15 | 2011-12-31 | XC603110, P3U10S2A (other project), P3U10S2D (other project) |  |  |  |  | 40d | 0d |  | Static Equipment < 10 tons [5 t]; Static equipment < 10t [500 h] | 20,000 |  | 500,00 |  | MI-21501 | 500 | 0 |  |  | 31 |  |  |  |  |  | X | B |  | 3110 |  |  |  |  |  |  | OMUS-1 |  |  |  |  |  |  |  |  |  |  |  | EQ |  | 5000 | concrete +0.150 | MI-21501 | SK3110 | PU10 CONVEYING SYSTEM (PK-21501) ZEPPELIN |  |  |  |  |  |  | 5 |  |  |  |
| MI-21502 |  | TRUCK LOADING SCALE |  | 15d | 2011-12-15 | 2011-12-31 | XC603110, P3U10S2A (other project), MI-21501 SS, P3U10S2D (other project) |  |  |  |  | 112d | 30d |  | Static Equipment < 10 tons [5 t]; Static equipment < 10t [500 h] | 20,000 |  | 500,00 |  | MI-21502 | 500 | 0 |  |  | 31 |  |  |  |  |  | X | B |  | 3110 |  |  |  |  |  |  | OMUS-1 |  |  |  |  |  |  |  |  |  |  |  | EQ |  | 5000 | concrete +0.150 | MI-21502 | SK3110 | PU10 CONVEYING SYSTEM (PK-21501) ZEPPELIN |  |  |  |  |  |  | 5 |  |  |  |
| PK-31201A/B |  | FFS BAGGING |  | 45d | 2011-12-15 | 2012-02-11 | XM003110 SS |  |  |  |  | -35d | 0d |  | Static Equipment < 10 tons [10 t]; Static equipment < 10t [1000 h] | 40,000 |  | 1000,00 | Haver & Boecker | PK-31201A/B | 1000 | 0 |  |  | 31 |  |  |  |  |  | X | B |  | 3110 |  |  |  |  |  |  | OMUS-1 |  |  |  |  |  | 022 |  |  |  |  |  | EQ |  | 10000 | concrete +10.65 | PK-31201A/B | SK3110 | PU06 BAGGING SYSTEM (PK-31201A/B) | 2 DC 9010 | 2011-01-25 | 2011-02-25 | 2011-04-05 | 2011-06-20 |  |  |  |  |  |
| XM003110 |  | CA31 SiloStruc - Install Bagging Eqpt |  | 40d | 2011-12-15 | 2012-02-06 | P3U06S (other project), P3A13S3B (other project), XC603110 |  |  |  |  | -35d | 0d |  |  |  |  | 16 |  | XM003110 | 0 | 0 | 934 | XBB | 31 | 2DC9010 | 200 | 200 | C | LND | X | B | XM00 | 3110 | B | 31 | X | EQ | LND | 3110 | OMUS-1 | 2011-04-20 | 2011-10-30 | E-08-01-18 |  |  |  |  |  |  |  |  |  |  |  |  |  |  |  |  |  |  |  |  |  |  | P | 2011-12-30 | 2011-12-30 |
| XX-31201 A/B |  | AUTOMATIC DOCKING DEVICE |  | 12.5d | 2011-12-15 | 2011-12-29 | XM003110 SS |  |  |  |  | 114.5d | 32.5d |  | Static Equipment < 10 tons [0.6 t]; Static equipment < 10t [60 h] | 2,400 |  | 60,00 |  | XX-31201 A/B | 60 | 0 |  |  | 31 |  |  |  |  |  | X | B |  | 3110 |  |  |  |  |  |  | OMUS-1 |  |  |  |  |  | 022 |  |  |  |  |  | EQ |  | 10000 | elev +17.00 | XX-31201 A/B | SK3110 | PU06 BAGGING SYSTEM (PK-31201A/B) |  | 2011-01-25 | 2011-02-25 | 2011-04-05 | 2011-06-20 |  |  |  |  |  |
| XX-31203 A/B |  | ELECTRONIC NET WEIGHER |  | 12.5d | 2011-12-15 | 2011-12-29 | XM003110 SS |  |  |  |  | 114.5d | 32.5d |  | Static Equipment < 10 tons [0.7 t]; Static equipment < 10t [70 h] | 2,800 |  | 70,00 |  | XX-31203 A/B | 70 | 0 |  |  | 31 |  |  |  |  |  | X | B |  | 3110 |  |  |  |  |  |  | OMUS-1 |  |  |  |  |  | 022 |  |  |  |  |  | EQ |  | 10000 | concrete +16.00 | XX-31203 A/B | SK3110 | PU06 BAGGING SYSTEM (PK-31201A/B) |  | 2011-01-25 | 2011-02-25 | 2011-04-05 | 2011-06-20 |  |  |  |  |  |
| XX-31205 A/B |  | MOBILE CHASSIS WHEEL TYPE |  | 12.5d | 2011-12-15 | 2011-12-29 | XM003110 SS |  |  |  |  | 114.5d | 32.5d |  | Static Equipment < 10 tons [0.6 t]; Static equipment < 10t [60 h] | 2,400 |  | 60,00 |  | XX-31205 A/B | 60 | 0 |  |  | 31 |  |  |  |  |  | X | B |  | 3110 |  |  |  |  |  |  | OMUS-1 |  |  |  |  |  | 022 |  |  |  |  |  | EQ |  | 10000 | concrete +10.65 | XX-31205 A/B | SK3110 | PU06 BAGGING SYSTEM (PK-31201A/B) |  | 2011-01-25 | 2011-02-25 | 2011-04-05 | 2011-06-20 |  |  |  |  |  |
| F-21504 A-D |  | TRANSFER AIR INLET FILTER |  | 30d | 2011-12-20 | 2012-01-30 | XB003120 SS |  |  |  |  | 357.5d |  |  | Static Equipment < 10 tons; Static equipment < 10t |  |  | 0,00 |  | F-21504 A-D | 0 | 0 |  |  | 31 |  |  |  |  |  | X | B |  | 3120 |  |  |  |  |  |  | OMUS-1 |  |  |  |  |  |  |  |  |  |  |  | EQ |  | 960 |  | F-21504 A-D | SK3110 | PU10 CONVEYING SYSTEM (PK-21501) ZEPPELIN |  |  |  |  |  |  |  |  |  |  |
| F-21505A-E |  | TRANSFER AIR INLET FILTER |  | 30d | 2011-12-20 | 2012-01-30 | XB003120 SS |  |  |  |  | 357.5d |  |  | Static Equipment < 10 tons; Static equipment < 10t |  |  | 0,00 |  | F-21505A-E | 0 | 0 |  |  | 31 |  |  |  |  |  | X | B |  | 3120 |  |  |  |  |  |  | OMUS-1 |  |  |  |  |  |  |  |  |  |  |  | EQ |  | 960 |  | F-21505A-E | SK3110 | PU10 CONVEYING SYSTEM (PK-21501) ZEPPELIN |  |  |  |  |  |  |  |  |  |  |
| HO-30326 |  | TROLLEY ELECTRICAL |  | 3.75d | 2012-01-17 | 2012-01-20 | XB003140 SS |  |  |  |  | 365.75d |  |  | Static Equipment < 10 tons [0.3 t]; Static equipment < 10t [30 h] | 1,200 |  | 30,00 |  | HO-30326 | 30 | 0 |  |  | 31 |  |  |  |  |  | X | B |  | 3140 |  |  |  |  |  |  | OMUS-1 |  |  |  |  |  |  |  |  |  |  |  | EQ |  | 1270 |  | HO-30326 | SK3140 | A12 OVERHEAD CRANES / TROLLEYS (incl. in Civil Subcontract) |  |  | 2011-01-09 |  | 2011-02-01 |  |  |  |  |  |
| XB50311020 |  | CA31 - Assembling Elevator |  | 46d | 2012-03-26 | 2012-05-19 |  |  |  |  |  | -11d | 0d | start on or after 2012-03-26 |  |  |  | 2750,00 | Jansens & Dieperink | XB50311010 | 697 | 0 | 934 | XBB | 31 |  | 200 | 200 | C | LND | X | B | XB90 | 3100 | B | 31 | X | EQ | LND | 3100 |  | 2011-02-20 | 2011-04-01 | E-08-01-03 |  | XB50311010 | 021 |  |  |  |  |  |  |  |  |  |  |  |  |  |  |  |  |  |  |  |  |  |  |
| XB50170320 |  | CA17 ExtrBldg SK1701- Assembling Elevators |  | 46d | 2012-05-21 | 2012-07-13 | XC40174010, XB50311020 |  |  |  |  | -11d | 84.5d |  |  |  |  | 2750,00 | Jansens & Dieperink | XB50311010 | 697 | 0 | 934 | XBB | 17 |  | 200 | 200 | C | LND | X | B | XB90 | 1700 | B | 17 | X | EQ | LND | 1700 |  | 2011-02-20 | 2011-04-01 | E-08-01-03 |  | XB50311010 | 021 |  |  |  |  |  |  |  |  |  |  |  |  |  |  |  |  |  |  |  |  |  |  |

Notes:
- XM003110: Current Status: 110315 (WL): Add PRED XC603110 CA31 SiloStruc - Paving inside / 110315 (WL): Delete PRED XC503110 CA31 SiloStruc - Finishing Work Bagging / Sec / 110315 (WL): Delete PRED XH00311005 CA31 SiloStruc - Installation HVAC

| ID | WBS | Activity | Duration | Start | Finish | Predecessors | Complete | Remaining | Planned start | Planned finish | Total float | Free float | Calendar | Resources | Cost | Actual cost | TB26 Ressource Budget | UDF_CONTRACT INDICATOR | UDF_SELECT UPDATE PROGRESS | UDF_SAVE ACT ID | UDF_BUDGETED LABOR UNIT | UDF_ACTUAL LABOR UNIT | UDF_CHECK RESOURCE DATES | Department | Type of Work | Constr. Area | Inquiry/Order No | PMT-Area | PMT-Schedule Org | PMT-Phase | PMT-Respons. | WBS Phase | WBS Discipline | WBS Type of Work | WBS Objects | Russia WBS Discipline (Russia) | Russia Construction Area | Russia WBS Phase | IMS | UPT | Russia WBS Objects | Subcontractor | UDF_CONTRACT START DATE | UDF_CONTRACT FINISH DATE | UDF_CONTRACT ITEM | UDF_PLANNED START | UDF_COMMENTS_0827 | UDF_PLANNED FINISH | UDF_CONTRACT FINISH DATE REV1 | UDF_CONTRACT START DATE REV1 | UDF_INDICATOR | TB26 Semantics | TB26 Material Res Values | UDF_ELECTRICAL START | UDF_ELECTRICAL FINISH | UDF_CHECK BASELINE | Filter | UDF_Vendor Representatives | geplanter Start | geplantes Ende | UDF_PENALIZED FINISH |
| --- | --- | --- | --- | --- | --- | --- | --- | --- | --- | --- | --- | --- | --- | --- | --- | --- | --- | --- | --- | --- | --- | --- | --- | --- | --- | --- | --- | --- | --- | --- | --- | --- | --- | --- | --- | --- | --- | --- | --- | --- | --- | --- | --- | --- | --- | --- | --- | --- | --- | --- | --- | --- | --- | --- | --- | --- | --- | --- | --- | --- | --- |
|  | M | **Mechanical - Rotating Equipment** |  |  |  |  |  |  |  |  |  |  |  |  |  |  |  |  |  |  |  |  |  |  |  |  |  |  |  |  |  |  |  |  |  |  |  |  |  |  |  |  |  |  |  |  |  |  |  |  |  |  |  |  |  |  |  |  |  |  |  |
|  | R | **Piping** |  | 2011-04-21 | 2012-06-25 |  |  |  |  |  |  |  |  |  |  |  |  |  |  |  |  |  |  |  |  |  |  |  |  |  |  |  |  |  |  |  |  |  |  |  |  |  |  |  |  |  |  |  |  |  |  |  |  |  |  |  |  |  |  |  |  |
| XR203110 |  | CA31 SiloStruc - Piping Prefabrication | 110d | 2011-04-21 A | 2011-09-01 | P3R06S1 (other project) FF+20d, P3R06CS1 (other project) FF+20d, P3R06DS1 (other project) FF+20d, P3A00D (other project), P3R06BS1 (other project), P3R06AS1 (other project) FF+20d, P3U10S1 (other project), ER493110 (other project) SS+18d, P3R06AS (other project) FF+20d, EL1040 (other project) FF+20d, ER49311005 (other project) SS+18d |  | 3d | 2011-04-21 | 2011-08-30 | 16d | 194d |  | A/G piping prefabrication [1140 Fpi]; Conveying S. piping prefabrication [3200 Fpi]; A/G Piping (Prefab) [4275 h]; Conveying system (Prefab) [8000 h] | 328,096.71 | 160,000 | 12275,00 | UDF_G4 | 27.8. | XR203110 | 12275 | 4600 | actual finish | 934 | ALL4 | 31 | 2DC8990 | 200 | 200 | C | LND | X | R | XR20 | 3110 | R | 31 | X | PRP | LND | 3110 | OMUS-1 |  |  |  |  |  |  |  |  |  |  |  |  |  |  |  |  |  |  |  |
| XR403110 |  | CA31 SiloStruc - Piping Installation | 148d | 2011-11-07 | 2012-05-07 | XN403110 SS+5d, XR203110 FF+10d, P3R07AS1 (other project), P3S01S (other project), P3S02S (other project) FF, P3J04IS (other project), XN603110 SS+5d, P3J04CS1 (other project), P3R03AS1 (other project) FF+20d, P3R04S1 (other project) FF+20d, XR200C10, P3S07S (other project) FF+20d, P3R03BS1 (other project) FF+20d, XB50311010 FS-12d, XN203110 |  |  |  |  | -158d | 0d |  | Install Control & Shut-off Valves [147 h]; A/G Piping (Field) [8750 h]; Conveying S. piping field installation [5600 Fpi]; Conveying system (Field) [28000 h]; Deluge Piping [5800 Fpi]; Deluge piping [36250 h]; A/G piping field installation [1400 Fpi]; Control & Shut-off valves [28 pcs] | 2,324,660.09 |  | 73147,00 |  | 27.8. | XR403110 | 73147 | 0 |  | 934 | ALL4 | 31 | 2DC8990 | 200 | 200 | C | LND | X | R | XR40 | 3110 | R | 31 | X | PI | LND | 3110 | OMUS-1 | 2011-03-01 | 2012-01-30 | E-06-03-08 | 2011-06-28 | start after roof installation + 2 weeks |  |  |  |  |  |  |  |  |  |  |  |  |  |  |
| XR603110 |  | CA31 SiloStruc - Piping Pressure Tests | 90d | 2012-02-25 | 2012-06-13 | XR600C00 SS, XR40311005 (other project) FF+20d, X0300020, XR403110 FF+30d |  |  |  |  | -81d | 0d |  |  |  |  | 957 |  |  | XR603110 | 0 | 0 |  | 934 | ALL4 | 31 | 2DC8990 | 200 | 200 | C | LND | X | R | XR60 | 3110 | R | 31 | X | HY | LND | 3110 | OMUS-1 | 2011-03-01 | 2012-01-30 | E-06-03-08 |  |  |  |  |  |  |  |  |  |  |  |  |  |  |  |  |
| XR803110 |  | CA31 SiloStruc - Piping Reinstatement | 60d | 2012-04-13 | 2012-06-25 | IMS-C-000360 FF, XR603110 FF+10d |  |  |  |  | -81d | 0d |  |  |  |  | 479 |  |  | XR803110 | 0 | 0 |  | 934 |  | 31 |  | 200 | 200 | C | LND | X | R | XR80 | 3110 | R | 31 | X | PI | LND | 3110 | OMUS-1 | 2011-03-01 | 2012-01-30 | E-06-03-08 |  |  | 2012-05-28 |  |  |  |  |  |  |  |  |  |  |  |  |  |
|  | E | **Electrical** |  | 2010-05-24 | 2012-10-05 |  |  |  |  |  |  |  |  |  |  |  |  |  |  |  |  |  |  |  |  |  |  |  |  |  |  |  |  |  |  |  |  |  |  |  |  |  |  |  |  |  |  |  |  |  |  |  |  |  |  |  |  |  |  |  |  |
| XC913110 |  | CA31 SiloStruc - Install Earthing&Lightn.System_CIVIL | 84d | 2010-05-24 A | 2010-08-28 A | XC20311005 SS, EE903110 (other project), EE900010 (other project) | 100% |  |  |  |  |  |  | Grounding & Lightning [680 pcs]; Grounding & Lightning [7650 h] | 306,000 | 306,000 | 7650,00 |  |  | XC913110 | 7650 | 7650 |  | 934 |  | 31 |  | 200 | 200 | C | LND | X | C | XE91 | 3110 | C | 31 | X | EA | LND | 3110 | MO11 | 2011-06-30 | 2011-12-30 | E-17-07-11 |  |  |  |  |  |  |  |  |  |  |  |  |  |  |  |  |
| XE913110 |  | CA31 SiloStruc - Install Earthing&Lightn.System_E/I | 15d | 2011-12-29 | 2012-01-23 | XN203110, XC40311015_110, BG-31201 A/B |  |  |  |  | 132.5d | 227.5d |  |  |  |  | 760 |  |  | XE913110 | 0 | 0 |  | 934 |  | 31 |  | 200 | 200 | C | LND | X | E | XE91 | 3110 | E | 31 | X | EA | LND | 3110 | URMA | 2011-06-30 | 2011-12-30 | E-16-07-11 |  |  |  | 2012-05-30 | 2011-11-01 | UDF_G2 |  |  |  |  |  |  |  |  |  |  |
| XE403110 |  | CA31 SiloStruc - Install Cable Trays | 50d | 2012-02-25 | 2012-04-24 | XN803110 FS-25d, XN803110S FS-25d, XR403110 FS-60d, P3E16S (other project), EE46311010 (other project), EE46510120 (other project) FF |  |  |  |  | -158d | 0d |  | Cable trays/conduits [2500 m]; Cable trays [7500 h] | 300,000 |  | 7500,00 |  |  | XE403110 | 7500 | 0 |  | 934 |  | 31 |  | 200 | 200 | C | LND | X | E | XE40 | 3110 | E | 31 | X | EL | LND | 3110 | URMA | 2011-06-30 | 2011-10-30 | E-15-01-13 |  | to be checked |  | 2012-02-15 | 2011-10-01 | UDF_G2 | m | 2650 | 2011-10-03 | 2011-12-12 | x |  |  |  |  |  |
| XE343110 |  | CA31 SiloStruc - Install Local Operation Panels | 50d | 2012-03-27 | 2012-05-25 | XE403110 FS-25d, EE46311010 (other project), XR403110 FS-60d |  |  |  |  | 261.5d |  |  | Field Panels [38 pcs]; Field panels [760 h] | 30,400 |  | 760,00 |  |  | XE343110 | 760 | 0 |  | 934 |  | 31 |  | 200 | 200 | C | LND | X | E | XE34 | 3110 | E | 31 | X | EL | LND | 3110 | URMA | 2011-06-30 | 2011-12-30 | E-16-07-11 |  | will be installed later |  | 2012-05-30 | 2011-11-01 | UDF_G2 |  |  |  |  |  |  |  |  |  |  |
| XE703110 |  | CA31 SiloStruc - Install Lighting & Small Power | 100d | 2012-03-27 | 2012-07-24 | P3E03S2 (other project) FS+10d, P3E09S (other project), XN603110, EE763110 (other project), XP341610 FS+50d, XE403110 FS-25d, XC603110, EE76510110 (other project), XH00311005_1 SS+15d, XC503110 SS+30d |  |  |  |  | -20d | 0d |  | Cable Pulling [5900 m]; Lighting illuminates [300 pcs]; Lighting (iluminates) [3000 h]; Cable pulling [2950 h] | 238,000 |  | 5950,00 |  |  | XE703110 | 5950 | 0 |  | 934 |  | 31 |  | 200 | 200 | C | LND | X | E | XE70 | 3110 | E | 31 | X | EL | LND | 3110 | URMA | 2011-05-10 | 2012-01-31 | E-16-03-01 |  |  |  | 2012-05-10 | 2011-08-15 | UDF_G2 |  |  |  |  |  | x |  |  |  |  |
| XE803110 |  | CA31 SiloStruc - Install Heat Tracing | 20d | 2012-05-21 | 2012-06-13 | E3E1950 (other project), RF-21503, P3E19S (other project), XR403110 FS-60d, XR603110 FS-20d |  |  |  |  | 42d | 0d |  | Electrical Heat Tracing [200 m]; Electrical heat tracing [100 h] | 4,000 |  | 100,00 |  |  | XE803110 | 100 | 0 |  | 934 |  | 31 |  | 200 | 200 | C | LND | X | E | XE80 | 3110 | E | 31 | X | HT | LND | 3110 | URMA | 2011-06-20 | 2012-03-20 | E-16-04-01 |  | will be installed later |  | 2012-06-30 | 2011-09-15 | UDF_G2 |  |  |  |  |  |  | 005 |  |  |  |
| XE503110 |  | CA31 SiloStruc - Cable Pulling Electric | 60d | 2012-07-04 | 2012-09-12 | XE500C01, P3E15AS (other project), EE563110 (other project), XE505601 FS-25d, XE403110 FS-20d, P3E15CS (other project), P3E15BS (other project) |  |  |  |  | -82.5d | 0d | TB26 - V - Construct-Winter partly * | Cable Pulling [11100 m]; Cable pulling [5550 h] | 222,000 |  | 5550,00 |  |  | XE503110 | 5550 | 0 |  | 934 |  | 31 |  | 200 | 200 | C | LND | X | E | XE50 | 3110 | E | 31 | X | EL | LND | 3110 | URMA | 2011-05-20 | 2012-02-10 | E-16-01-01 |  |  |  | 2012-07-01 | 2011-10-01 | UDF_G2 | m | 11500 | 2011-12-13 | 2012-02-28 |  |  |  |  |  |  |
| XE923110 |  | CA31 SiloStruc - Install Fire Detection System | 60d | 2012-07-25 | 2012-10-02 | XH00311005, XN603110 SS+40d, XJ423110, XC503110, XE703110, XH00311005_1 |  |  |  |  | 151.5d | 0d |  | Fire Detection System; Fire detection system |  |  | 0,00 |  |  | XE923110 | 0 | 0 |  | 934 |  | 31 |  | 200 | 200 | C | UIO | X | E | XE92 | 3110 | E | 31 | X | FGDS | LND | 3110 |  |  |  |  |  |  |  |  |  |  |  |  |  |  | x | x |  | 2012-02-14 | 2012-06-27 |  |
| XE963110 |  | CA31 SiloStruc - Install Communication System | 60d | 2012-07-25 | 2012-10-02 | XE703110, P3E13S (other project), XE923110 SS, XC503110, XJ423110, XH00311005 |  |  |  |  | 151.5d |  |  | Communication System |  |  | 0,00 |  |  | XE963110 | 0 | 0 |  | 934 |  | 31 |  | 200 | 200 | C | LND | X | E | XE96 | 3110 | E | 31 | X | CS | LND | 3110 |  |  |  |  |  |  |  |  |  |  |  |  |  |  | x | x |  | 2012-02-14 | 2012-06-27 |  |
| XE603110 |  | CA31 SiloStruc - Cable Termination & Testing | 50d | 2012-08-08 | 2012-10-05 | XE503110 FS-30d |  |  |  |  | -82.5d | 0d |  | Cable connecting [210 pcs]; Cable connecting [525 h] | 21,000 |  | 525,00 |  |  | XE603110 | 525 | 0 |  | 934 |  | 31 |  | 200 | 200 | C | LND | X | E | XE60 | 3110 | E | 31 | X | ET | LND | 3110 | URMA | 2011-04-20 | 2011-11-30 | E-16-02-01 |  |  |  | 2012-08-14 | 2011-12-10 | UDF_G2 |  |  |  |  |  |  |  |  |  |  |
|  | J | **Instrumentation** |  | 2012-02-25 | 2012-11-16 |  |  |  |  |  |  |  |  |  |  |  |  |  |  |  |  |  |  |  |  |  |  |  |  |  |  |  |  |  |  |  |  |  |  |  |  |  |  |  |  |  |  |  |  |  |  |  |  |  |  |  |  |  |  |  |  |
| XJ323110 |  | CA31 SiloStruc - Install Junction Boxes | 40d | 2012-02-25 | 2012-04-12 | P3J06ES (other project) FS+14d, EJ323110 (other project), P3J06FS (other project), XR403110 FS-60d, EJ32171005 (other project), BG-31201 A/B, PK-31201A/B |  |  |  |  | -45d | 5d |  | Junction Boxes/Cabinets/Panels [37 pcs]; Install Junction Boxes/ Cabinets/ Panels [925 h] | 37,000 |  | 925,00 |  |  | XJ323110 | 925 | 0 |  | 934 |  | 31 |  | 200 | 200 | C | LND | X | J | XJ32 | 3110 | J | 31 | X | IN | LND | 3110 | URMA | 2011-06-30 | 2012-03-30 | E-17-04-11 |  | will be installed later |  | 2012-08-10 | 2011-11-15 | UDF_G2 |  |  |  |  |  |  |  |  |  |  |
| XJ423110 |  | CA31 SiloStruc - Install Secondary Cable Trays | 40d | 2012-03-27 | 2012-05-14 | EJ46311010 (other project), EJ143130 (other project), XE403110 FS-25d, XJ323110 FS-20d, XR403110 FS-60d, PK-31201A/B |  |  |  |  | -21d | 55d |  | Secondary cable trays [560 m]; Install secondary cable trays [2100 h] | 84,000 |  | 2100,00 |  |  | XJ423110 | 2100 | 0 |  | 934 |  | 31 |  | 200 | 200 | C | LND | X | J | XJ42 | 3110 | J | 31 | X | IN | LND | 3110 | URMA | 2011-06-30 | 2011-10-30 | E-15-01-13 |  |  |  | 2012-02-15 | 2011-10-01 | UDF_G2 | m | 850 | 2011-10-03 | 2011-12-12 | x | x |  |  |  |  |
| XJ443110 |  | CA31 SiloStruc - Install Conduits to Instrm | 70d | 2012-04-25 | 2012-07-18 | XJ323110 FS-10d, XE403110, XR403110 FS-60d, PK-31201A/B |  |  |  |  | -65d | 0d |  |  |  |  |  |  |  | XJ443110 | 0 | 0 |  | 934 |  | 31 |  | 200 | 200 | C | LND | X | J | XJ44 | 3110 | J | 31 | X | IN | LND | 3110 | URMA | 2011-06-30 | 2012-03-30 | E-17-04-11 |  | to be checked |  | 2012-08-10 | 2011-11-15 | UDF_G2 |  |  |  |  |  |  |  |  |  |  |
| XJ303110 |  | CA31 SiloStruc - Install Field Instruments | 70d | 2012-05-21 | 2012-08-10 | EJ363110 (other project), XR803110 FS-30d, EJ360010 (other project), P3J05S (other project), XR403110 FS-60d, BG-31201 A/B, PK-31201A/B |  |  |  |  | -81d | 0d |  | Field Instruments [50 pcs]; Install field instruments [275 h] | 11,000 |  | 275,00 |  |  | XJ303110 | 275 | 0 |  | 934 |  | 31 |  | 200 | 200 | C | LND | X | J | XJ30 | 3110 | J | 31 | X | IN | LND | 3110 | URMA | 2011-06-30 | 2012-03-30 | E-17-04-11 |  |  |  | 2012-08-10 | 2011-11-15 | UDF_G2 |  |  |  |  |  |  |  |  |  |  |
| XJ523110 |  | CA31 SiloStruc - Pulling Multicore Cables | 40d | 2012-06-09 | 2012-07-27 | XE500C01, XJ323110 FS-20d, XJ525601 SS+5d, P3J17S1 (other project), XE405503 |  |  |  |  | 189d | 0d | TB26 - V - Construct-Winter partly * | Multicore cables [3000 m]; Pull multicore cables [1500 h] | 60,000 |  | 1500,00 |  |  | XJ523110 | 1500 | 0 |  | 934 |  | 31 |  | 200 | 200 | C | LND | X | J | XJ52 | 3110 | J | 31 | X | IN | LND | 3110 | URMA | 2011-05-20 | 2012-03-10 | E-17-01-01 |  |  |  | 2012-06-16 | 2011-11-01 | UDF_G2 | m | 2150 | 2011-12-21 | 2012-02-11 |  |  |  |  |  |  |
| XJ543110 |  | CA31 SiloStruc - Pulling Singlecore Cables | 40d | 2012-07-02 | 2012-08-16 | XE500C01, EJ803110 (other project), XJ443110 FS-35d, XJ303110 FS-35d, XJ423110 FS-20d |  |  |  |  | -80d | 0d | TB26 - V - Construct-Winter partly * | Singlecore cables [3500 m]; Pull singlecore cables [2625 h] | 105,000 |  | 2625,00 |  |  | XJ543110 | 2625 | 0 |  | 934 |  | 31 |  | 200 | 200 | C | LND | X | J | XJ54 | 3110 | J | 31 | X | IN | LND | 3110 | URMA | 2011-06-30 | 2012-03-30 | E-17-04-11 |  |  |  | 2012-08-10 | 2011-11-15 | UDF_G2 | m | 3383 | 2012-01-20 | 2012-03-07 |  |  |  |  |  |  |
| XJ703110 |  | CA31 SiloStruc - Instrument Tubing | 40d | 2012-07-02 | 2012-08-16 | XJ303110 FS-35d |  |  |  |  | -80d | 0d |  |  |  |  |  |  |  | XJ703110 | 0 | 0 |  | 934 |  | 31 |  | 200 | 200 | C | LND | X | J | XJ70 | 3110 | J | 31 | X | IN | LND | 3110 | URMA | 2011-06-30 | 2012-03-30 | E-17-04-11 |  |  |  | 2012-08-10 | 2011-11-15 | UDF_G2 |  |  |  |  |  |  |  |  |  |  |
| XJ623110 |  | CA31 SiloStruc - Termin Multicore Cables | 40d | 2012-07-04 | 2012-08-20 | XH00311005, XJ523110 FS-20d, XH00311005_1 FS-20d, XJ323110 FS-20d |  |  |  |  | 189d |  |  | Termination Field [2118 mhr]; Termination field [2118 h] | 211,800 |  | 2118,00 |  |  | XJ623110 | 2118 | 0 |  | 934 |  | 31 |  | 200 | 200 | C | LND | X | J | XJ62 | 3110 | J | 31 | X | IN | LND | 3110 | URMA | 2011-05-20 | 2012-03-10 | E-17-01-01 |  |  |  | 2012-06-16 | 2011-11-01 | UDF_G2 |  |  |  |  |  |  |  |  |  |  |
| XJ393110 |  | CA31 SiloStruc - Install Earthing Field Eqpt | 50d | 2012-07-19 | 2012-09-14 | XJ303110 FS-35d, XJ423110, XJ443110 |  |  |  |  | -65d | 12.5d |  |  |  |  |  |  |  | XJ393110 | 0 | 0 |  | 934 |  | 31 |  | 200 | 200 | C | LND | X | J | XJ39 | 3110 | J | 31 | X | IN | LND | 3110 | URMA | 2011-06-30 | 2012-03-30 | E-17-04-11 |  |  |  | 2012-08-10 | 2011-11-15 | UDF_G2 |  |  |  |  |  |  |  |  |  |  |
| XJ643110 |  | CA31 SiloStruc - Termin Singlecore Cables | 60d | 2012-07-25 | 2012-10-02 | XJ543110 FS-20d, XJ323110 FS-20d, XJ703110 FS-20d |  |  |  |  | -80d | 7.5d |  | Termination Field [2117 mhr]; Termination field [2117 h] | 211,700 |  | 2117,00 |  |  | XJ643110 | 2117 | 0 |  | 934 |  | 31 |  | 200 | 200 | C | LND | X | J | XJ64 | 3110 | J | 31 | X | IN | LND | 3110 | URMA | 2011-06-30 | 2012-03-30 | E-17-04-11 |  |  |  | 2012-08-10 | 2011-11-15 | UDF_G2 |  |  |  |  |  |  |  |  |  |  |
| XJ803110 |  | CA31 SiloStruc - Inspections/ Mech. Acceptance/ Loop Checks | 60d | 2012-09-06 | 2012-11-16 | XJ643110 FS-30d, XJ393110 FS-20d, X3J100 FF, X0300015, IMS-C-000420 FF, XE603110 FS-25d, XJ800C00, X3J120, XJ703110 FS-20d, X030410030, EJ803110 (other project) |  |  |  |  | -70.5d | 0d |  | Loop Checks [210 pcs]; Loop checks [1050 h] | 42,000 |  | 1050,00 |  |  | XJ803110 | 1050 | 0 |  | 934 |  | 31 |  | 200 | 200 | C | LND | X | J | XJ80 | 3110 | J | 31 | X | LT | LND | 3110 | URMA | 2011-06-10 | 2012-04-30 | E-17-02-01 |  |  |  | 2012-08-18 | 2012-03-01 | UDF_G2 |  |  |  |  |  |  |  |  |  | 2012-08-18 |

Notes:
- XE913110: UDF_PREDECESSOR: XN30, DEL XE40, DEL XE80, DEL XJ40, Civil 100%, Equipment 100%
- XE403110: UDF_PREDECESSOR: XN30, Piping 50%
- XE343110: UDF_PREDECESSOR: XE40, Equipment 100%, Piping 50%
- XE703110: UDF_PREDECESSOR: XE40, Civil 100%, HVAC ducts, Finishing works partly
- XE803110: Current Status: 110315 (WL): Delete PRED XM003110 CA31 SiloStruc - Install Bagging Eqpt / 110315 (WL): Delete PRED XB50311010 CA31 SiloStruc - Install Silos / Blenders / UDF_PREDECESSOR: XR40, Piping 50% pressure tests
- XE503110: UDF_PREDECESSOR: XE40, XE50, DEL XE34
- XE923110: Scope: CA31: / FDS - 146external sensors / Structured Cable System (SCS) / FOCL / DS + SAME / MDCN
- XE963110: Scope: CA31: / FDS - 146external sensors / Structured Cable System (SCS) / FOCL / DS + SAME / MDCN
- XE603110: UDF_PREDECESSOR: XE50, Equipment 100%
- XJ323110: UDF_PREDECESSOR: Civil 100%, Equipment 100%, Piping 50%
- XJ423110: UDF_PREDECESSOR: XE40, XJ32, Equipment 100%, Piping 50%
- XJ443110: UDF_PREDECESSOR: XE40, XJ32, XJ40, Equipment 100%, Piping 50%
- XJ303110: UDF_PREDECESSOR: XR80, XR40, Equipment 100%, Piping 50%
- XJ523110: UDF_PREDECESSOR: XE40, XJ32, XJ52
- XJ543110: UDF_PREDECESSOR: XJ30, XJ42, XJ44
- XJ703110: UDF_PREDECESSOR: XJ30
- XJ623110: UDF_PREDECESSOR: XJ32, XJ52
- XJ393110: UDF_PREDECESSOR: XJ30, XJ42, XJ44, DEL XJ32, DEL XR40
- XJ643110: UDF_PREDECESSOR: XJ30, XJ32, XJ39, XJ54, XJ70
- XJ803110: UDF_PREDECESSOR: XE60, XJ39, XJ62, XJ64, XJ70

| ID | WBS | Activity | Type | Duration | Start | Finish | Predecessors | Complete | Planned start | Planned finish | Total float | Free float | Constraint | Calendar | Resources | Cost | Actual cost | TB26 Ressource Budget | UDF_SAVE ACT ID | UDF_BUDGETED LABOR UNIT | UDF_ACTUAL LABOR UNIT | Department | Constr. Area | PMT-Area | PMT-Schedule Org | PMT-Phase | PMT-Respons. | WBS Phase | WBS Discipline | WBS Type of Work | WBS Objects | Russia WBS Discipline (Russia) | Russia Construction Area | Russia WBS Phase | IMS | UPT | Russia WBS Objects | Subcontractor | UDF_CONTRACT FINISH DATE | UDF_CONTRACT ITEM | UDF_CONTRACT DATE PENALIZED | UDF_PENALIZED START | UDF_PENALIZED FINISH | Inquiry/Order No | Zeigen/n. Zeigen | UDF_Text4 | 4 week lookahead | UDF_CONTRACT INDICATOR | UDF_SELECT UPDATE PROGRESS | UDF_CHECK RESOURCE DATES | UDF_Concrete | UDF_CHECK CRITICAL PATH | UDF_BASELINE DEVELOPMENT | Check ResLoading | UDF_SELECT | UDF_CHECK BASELINE | Type of Work | Comments | TB26 Semantics |
| --- | --- | --- | --- | --- | --- | --- | --- | --- | --- | --- | --- | --- | --- | --- | --- | --- | --- | --- | --- | --- | --- | --- | --- | --- | --- | --- | --- | --- | --- | --- | --- | --- | --- | --- | --- | --- | --- | --- | --- | --- | --- | --- | --- | --- | --- | --- | --- | --- | --- | --- | --- | --- | --- | --- | --- | --- | --- | --- | --- |
|  | S | **Safety & Environment** |  |  |  |  |  |  |  |  |  |  |  |  |  |  |  |  |  |  |  |  |  |  |  |  |  |  |  |  |  |  |  |  |  |  |  |  |  |  |  |  |  |  |  |  |  |  |  |  |  |  |  |  |  |  |  |  |  |
|  | W | **Painting** |  |  | 2012-04-25 | 2012-06-25 |  |  |  |  |  |  |  |  |  |  |  |  |  |  |  |  |  |  |  |  |  |  |  |  |  |  |  |  |  |  |  |  |  |  |  |  |  |  |  |  |  |  |  |  |  |  |  |  |  |  |  |  |  |
| XW503110 |  | CA31 SiloStruc - Surf.Protection Piping |  | 50d | 2012-04-25 | 2012-06-25 | XR403110 FF+30d, XR803110 FF |  |  |  | 236.5d |  |  |  | Piping painting [1206 sqm]; Piping painting [3015 h] | 198.08 |  | 3015,00 | XW503110 | 3015 | 0 | 934 | 31 | 200 | 200 | C | LND | X | W | XW50 | 3110 | W | 31 | X | PA | LND | 3110 | OMUS-1 |  |  |  |  |  |  |  |  |  |  |  |  |  |  |  |  |  |  |  |  |  |
|  | V | **Insulation** |  |  | 2012-02-13 | 2012-07-06 |  |  |  |  |  |  |  |  |  |  |  |  |  |  |  |  |  |  |  |  |  |  |  |  |  |  |  |  |  |  |  |  |  |  |  |  |  |  |  |  |  |  |  |  |  |  |  |  |  |  |  |  |  |
| XV303110 |  | CA31 SiloStruc - Insulation Equipment |  | 80d | 2012-02-13 | 2012-05-19 | RF-21517, HO-30307, HO-30301, HO-30309, HO-30318, XX-22501, RF-21503, HO-30314, HO-30320, HE-24101, RF-21501A/B/C, HO-30316, HO-30317, RF-22502, XC40311015_100, HO-30312, HO-30322, HO-30310, HO-30321, BG-31201 A/B, XX-31203 A/B, XX-31201 A/B, MI-21501, PK-31201A/B, XX-21501-F01, XC40311015_110, HO-30315, XB50311010, XM003110, RF-22501A/B/C, HO-30302, HO-30308, HO-30305, HO-30324, RF-22504, RF-21504, DV-21540, MI-31201, BL-31201A/B, XX-22501-F01, HO-30313, HO-30325, HO-30304, XX-22501-RF01, DV-22501-35, RF-21502, RF-21505-14, MI-21502, HO-30306, HO-30319, HO-30323, XX-31205 A/B, V-21504 A/B/C, XX-21501, DV-21501-35, F-31201A/B, PK-21503, HO-30311, HO-30303, DV-22540, HP-21501, MI-21503 |  |  |  | 82d | 40d |  |  | Equipment insulation [450 sqm]; Equipment insulation [5624 h] | 1,973.36 |  | 5624,00 | XV303110 | 5624 | 0 | 934 | 31 | 200 | 200 | C | LND | X | V | XV30 | 3110 | V | 31 | X | INS | LND | 3110 | OMUS-1 | 2012-03-30 | E-13-03 | P | 2012-03-30 | 2012-03-30 |  |  |  |  |  |  |  |  |  |  |  |  |  |  |  |  |
| XV503110 |  | CA31 SiloStruc - Insulation Piping |  | 80d | 2012-04-02 | 2012-07-06 | IMS-C-000210 FF, XE803110 FF+20d, XV303110 FF, XR603110 FF+20d |  |  |  | 42d | 112.5d |  |  | Piping insulation [1600 sqm]; Piping insulation [12000 h] | 7,887.55 |  | 12000,00 | XV503110 | 12000 | 0 | 934 | 31 | 200 | 200 | C | LND | X | V | XV50 | 3110 | V | 31 | X | INS | LND | 3110 | OMUS-1 | 2012-04-30 | E-13-01 | P | 2012-04-30 | 2012-04-30 | 2DC8990 |  |  |  |  |  |  |  |  |  |  |  |  |  |  |  |
|  | 15 | **CA31(3105) - Conveying Tower** |  |  |  |  |  |  |  |  |  |  |  |  |  |  |  |  |  |  |  |  |  |  |  |  |  |  |  |  |  |  |  |  |  |  |  |  |  |  |  |  |  |  |  |  |  |  |  |  |  |  |  |  |  |  |  |  |  |
|  | 20 | **CA31(3103) - Blower Room & Truck Inliner Loading** |  |  | 2009-11-24 | 2012-11-10 |  |  |  |  |  |  |  |  |  |  |  |  |  |  |  |  |  |  |  |  |  |  |  |  |  |  |  |  |  |  |  |  |  |  |  |  |  |  |  |  |  |  |  |  |  |  |  |  |  |  |  |  |  |
|  | C | **Civil Work** |  |  | 2009-11-24 | 2012-05-19 |  |  |  |  |  |  |  |  |  |  |  |  |  |  |  |  |  |  |  |  |  |  |  |  |  |  |  |  |  |  |  |  |  |  |  |  |  |  |  |  |  |  |  |  |  |  |  |  |  |  |  |  |  |
| XC153120 |  | CA31 Blower Sec - Piling outside SiloStructure |  | 74d | 2009-11-24 A | 2010-02-17 A | EC153120 (other project) FS+10d, XC11310005 FF, F2910 | 100% |  |  |  |  |  |  | Piles driven [316 pcs]; Piles driven [2370 h] | 94,800 | 94,800 | 2370,00 | XC153120 | 2370 | 2370 | 934 | 31 | 200 | 200 | C | MO01 | X | C | XC15 | 3120 | C | 31 | X | P | LND | 3120 | MO11 |  |  |  |  |  |  |  |  |  |  |  |  |  |  |  |  |  |  |  |  |  |
| XC403120 |  | CA31 Blower Sec - Concrete Works Bldg Fdtn |  | 46d | 2010-06-23 A | 2010-08-15 A | XC153120, IMS-C-000050 FF, XC20311005 SS+20d, EC45312005 (other project) SS+10d, EC48312005 (other project) FS+20d, EC45312015 (other project), EC48312003 (other project) FS+20d | 100% | 2010-06-23 | 2010-08-14 |  |  |  |  | Concrete works [500 cbm]; Concrete works [15000 h] | 7,594.13 |  | 15000,00 | XC403120 | 15000 | 15000 | 934 | 31 | 200 | 200 | C | MO03 | X | C | XC20 | 3120 | C | 31 | X | mai | LND | 3120 | MO11 |  |  |  |  |  |  | D |  |  |  |  |  |  |  |  |  |  |  |  |  |  |
| XC40312010 |  | CA31 Blower Sec SK3104 - Precast Concrete Elements |  | 39d | 2011-05-10 A | 2011-06-24 A | EC48312004 (other project), P3C02D3 (other project) FF, EC48312015 (other project) FF, XCC02D2 FS+147d, EC48312008 (other project) FF, EC48312006 (other project) | 100% |  |  |  |  |  |  |  |  |  |  | XC40312010 | 0 | 0 | 934 | 31 | 200 | 200 | C | MO04 | X | C | XC40 | 3120 | C | 31 | X | pre | LND | 3120 | MO11 |  |  |  |  |  |  | C7 | CA16 - critical - CW05 | x |  |  |  |  |  |  |  |  |  |  |  |  |
| XC40312015 |  | CA31 Blower Sec - Erection Precast Elements |  | 55d | 2011-05-25 A | 2011-07-29 A | XC40312010 FF+5d, EC45312015 (other project) | 100% | 2011-05-25 | 2011-07-28 |  |  |  |  | Precast Concrete Works [195 cbm]; Precast concrete works [488 h] | 19,500 | 19,200 | 488,00 | XC40312015 | 488 | 298 | 934 | 31 | 200 | 200 | C | MO04 | X | C | XC40 | 3120 | C | 31 | X | OB | LND | 3120 | MO11 |  |  |  |  |  |  | C7 | CA16 - critical - CW05 |  | UDF_G4 |  |  |  |  |  |  |  |  |  |  |  |
| XC40312020 |  | CA31 Blower Sec SK3104 - Concrete Works Ceiling |  | 54d | 2011-07-20 A | 2011-08-25 A | XC40312015 | 100% | 2011-07-20 | 2011-09-20 |  |  |  |  | Concrete works [820 cbm]; Concrete works [24600 h] | 984,000 | 984,000 | 24600,00 | XC40312020 | 24600 | 0 | 934 | 31 | 200 | 200 | C | MO04 | X | C | XC40 | 3120 | C | 31 | X | OB | LND | 3110 | MO11 |  |  | P | 2011-07-30 | 2011-07-30 |  | C7 | CA16 - critical - CW05 |  |  | 27.8. | x |  |  |  |  |  |  |  |  |  |
| XC40312022 |  | CA31 Blower Sec - Erection Precast Elements finished | milestone | 0d | 2011-07-28 A | 2011-07-28 A | XC40312015 FF | 100% | 2011-07-30 | 2011-07-30 |  |  |  |  |  |  |  |  | XC40312022 | 0 | 0 | 934 | 31 | 200 | 200 | C | MO04 | X | C | XC40 | 3120 | C | 17 | X | EB | LND | 1710 | MO11 |  |  | P | 2011-07-30 | 2011-07-30 |  | D |  |  |  |  |  |  |  |  |  |  |  |  |  |  |
| XC303120 |  | CA31 Blower Sec - UG Installation (incl. Precast Manholes) |  | 19d | 2011-09-05 | 2011-09-26 | P3R02S1 (other project), P3R02BS (other project), EC303120 (other project) FS+10d, XC40312015 SS+12d, XC300C00, P3R02AS1 (other project), ER443120 (other project), XC310C00 |  |  |  | -29d | 16d |  |  | Cast Iron U/G Piping [1520 m]; Concrete Manholes; Cast iron U/G piping [30400 h]; concrete manholes | 665.18 |  | 60800,00 | XC303120 | 30400 | 0 | 934 | 31 | 200 | 200 | C | CiC | X | C | XC30 | 3120 | C | 31 | X | UG | LND | 3120 |  |  |  |  |  |  |  |  |  |  |  | 27.8. | ok | 1 | XC303120 | XC303120 | UG |  |  |  |  |  |
| XC193120 |  | CA31 Blower Sec - Backfill inside |  | 35d | 2011-09-23 | 2011-11-02 | XC303120 FF, XC913120 FF+10d, XC303110 FF+15d, XC303120 SS |  |  |  | -45d | 0d |  | TB26 - T - Construct-Winter-3 (Dec/Jan/Feb free) * | Backfill & Compaction [3050 cbm]; Backfill & Compaction [4575 h] | 274,500 |  | 9150,00 | XC193120 | 4575 | 0 | 934 | 31 | 200 | 200 | C | MO04 | X | C | XC19 | 3120 | C | 31 | X | UG | LND | 3120 | MO11 |  |  |  |  |  |  |  |  |  |  | 27.8. |  |  |  | XC303120 | X |  |  |  |  |  |
| XC603120 |  | CA31 Blower Sec - Paving inside |  | 30d | 2011-09-29 | 2011-11-02 | EC603120 (other project) FS+20d, XC193120 FF |  |  |  | -45d | 7d |  |  | Concrete paved areas & concrete Roads [2100 sqm]; Concrete paved areas & concrete roads [7875 h] | 4,730.16 |  | 7875,00 | XC603120 | 7875 | 0 | 934 | 31 | 200 | 200 | C | MO04 | X | C | XC60 | 3120 | C | 31 | X | PV | LND | 3120 | MO11 |  |  |  |  |  |  | C7 | CA16 - critical - CW05 |  |  |  |  | 1 |  | XC303120 |  |  |  |  |  |  |
| XC503120 |  | CA31 Blower Sec - Finishing Works Rooms |  | 125d | 2011-10-21 | 2012-03-24 | XN803120 SS-20d, XC003120 FF+20d, XC510C00 FS+15d, EC503120 (other project), XC603120 SS-30d |  |  |  | 1d | 0d |  |  | Finishing Works - Warehouse CA31 [11943 mhr]; Finishing Works - Warehouse CA31 [11943 h] | 1,194,300 |  | 11943,00 | XC503120 | 11943 | 0 | 934 | 31 | 200 | 200 | C | CiC | X | C | XC50 | 3120 | C | 31 | X | OB | LND | 3120 |  |  |  |  |  |  |  |  |  |  |  |  |  | 1 |  |  | 31 | XC50 |  |  |  |  |
| XC503120_1 |  | CA31 Blower Sec - Plastering and Painting |  | 20d | 2011-10-21 | 2011-11-14 | XC503120 SS |  |  |  | 93d | 10d |  |  |  |  |  | 11943,00 | XC503120 | 11943 | 0 | 934 | 31 | 200 | 200 | C | CiC | X | C | XC50 | 3120 | C | 31 | X | OB | LND | 3120 |  |  |  |  |  |  |  |  |  |  |  |  |  | 1 |  |  | 31 |  |  |  |  |  |
| XC203120 |  | CA31 Blower Sec SK3104 - Concrete Works / ComprFdtn |  | 40d | 2011-11-03 | 2011-12-20 | XC193120, IMS-C-000050 FF, P3C02D3 (other project) FF, XC403120 FS+10d, P3C02D1 (other project) |  |  |  | 386.5d |  |  |  | Concrete works [180 cbm]; Concrete works [5400 h] | 3,695.44 |  | 5400,00 | XC203120 | 5400 | 0 | 934 | 31 | 200 | 200 | C | MO03 | X | C | XC40 | 3120 | C | 31 | X | mai | LND | 3120 | MO11 |  |  |  |  |  |  | D |  | x |  |  |  |  |  | XC303120 |  |  |  |  |  |  |
| XC303125 |  | CA31 Blower Sec - UG Installation (incl. Precast Manholes) |  | 30d | 2012-03-01 | 2012-04-06 |  |  |  |  | 266.64d | 0d | start on or after 2012-03-01 |  | Cast Iron U/G Piping [1520 m]; Concrete Manholes; Cast iron U/G piping [30400 h]; concrete manholes | 665.18 |  | 60800,00 | XC303120 | 30400 | 0 | 934 | 31 | 200 | 200 | C | CiC | X | C | XC30 | 3120 | C | 31 | X | UG | LND | 3120 |  |  |  |  |  |  |  |  |  |  |  |  |  | 1 | XC303120 | XC303120 | UG |  |  |  |  |  |
| XC193125 |  | CA31 Blower Sec - Backfill |  | 35d | 2012-04-06 | 2012-05-19 | XC303125 |  |  |  | 266.64d |  | start on or after 2012-03-02 | TB26 - T - Construct-Winter-3 (Dec/Jan/Feb free) * | Backfill & Compaction [3050 cbm]; Backfill & Compaction [4575 h] | 274,500 |  | 9150,00 | XC193120 | 4575 | 0 | 934 | 31 | 200 | 200 | C | MO04 | X | C | XC19 | 3120 | C | 31 | X | UG | LND | 3120 | MO11 |  |  |  |  |  |  |  |  |  |  |  |  |  |  | XC303120 | X |  |  |  |  |  |
|  | N | **Structural Steel** |  |  | 2011-04-21 | 2012-03-30 |  |  |  |  |  |  |  |  |  |  |  |  |  |  |  |  |  |  |  |  |  |  |  |  |  |  |  |  |  |  |  |  |  |  |  |  |  |  |  |  |  |  |  |  |  |  |  |  |  |  |  |  |  |
| XN763104 |  | CA31 Warehouse SK3104_40- KMD Assy Drawings (welded sections) | milestone | 0d | 2011-04-21 A | 2011-04-21 A |  | 100% |  |  |  |  | finish on 2011-04-21 |  |  |  |  | 22t | XN763104 | 0 | 0 | 934 | 31 | 200 | 200 | C | LND | X | N | XN05 | 3120 | N | 31 | X | SS | LND | 3120 |  |  |  |  |  |  |  | KMD |  |  |  |  |  |  |  |  |  |  | x | XNK |  |  |
| XN703104 |  | CA31 Blower Sec SK3104_01 - KMD Assy Drawings | milestone | 0d | 2011-04-22 A | 2011-04-22 A |  | 100% |  |  |  |  | finish on 2011-04-22 |  |  |  |  | 22t | XN703104 | 0 | 0 | 934 | 31 | 200 | 200 | C | LND | X | N | XN05 | 3120 | N | 31 | X | SS | LND | 3120 |  |  |  |  |  |  |  | KMD |  |  |  |  |  |  |  |  |  |  | x | XNK |  |  |
| XN723104 |  | CA31 Blower Sec SK3104_02 - KMD Assy Drawings | milestone | 0d | 2011-04-22 A | 2011-04-22 A |  | 100% |  |  |  |  | finish on 2011-04-22 |  |  |  |  | 22t | XN723104 | 0 | 0 | 934 | 31 | 200 | 200 | C | LND | X | N | XN05 | 3120 | N | 31 | X | SS | LND | 3120 |  |  |  |  |  |  |  | KMD |  |  |  |  |  |  |  |  |  |  | x | XNK |  |  |
| XN743104 |  | CA31 Blower Sec SK3104_03-11 - KMD Assy Drawings | milestone | 0d | 2011-04-22 A | 2011-04-22 A |  | 100% |  |  |  |  | finish on 2011-04-22 |  |  |  |  | 22t | XN743104 | 0 | 0 | 934 | 31 | 200 | 200 | C | LND | X | N | XN05 | 3120 | N | 31 | X | SS | LND | 3120 |  |  |  |  |  |  |  | KMD |  |  |  |  |  |  |  |  |  |  | x | XNK |  |  |
| XN713104 |  | CA31 Blower Sec SK3104_01- Steel Deliveries | milestone | 0d | 2011-07-30 A | 2011-07-30 A |  | 100% |  |  |  |  | finish on 2011-07-30 | TB26 - 3 - Construction Normal 7days * CA17 |  |  |  | 22t | XN713104 | 0 | 0 | 934 | 31 | 200 | 200 | C | LND | X | N | XN06 | 3120 | N | 31 | X | SS | LND | 3120 |  |  |  |  |  |  |  | SD |  |  |  | 27.8. |  |  |  |  |  |  |  | XNK |  |  |
| XN733104 |  | CA31 Blower Sec SK3104_02 - Steel Deliveries | milestone | 0d | 2011-07-30 A | 2011-07-30 A |  | 100% |  |  |  |  | finish on 2011-07-30 | TB26 - 3 - Construction Normal 7days * CA17 |  |  |  | 22t | XN733104 | 0 | 0 | 934 | 31 | 200 | 200 | C | LND | X | N | XN06 | 3120 | N | 31 | X | SS | LND | 3120 |  |  |  |  |  |  |  | SD |  |  |  | 27.8. |  |  |  |  |  |  |  | XNK |  |  |
| XN753104 |  | CA31 Blower Sec SK3104_03-11 - Steel Deliveries | milestone | 0d | 2011-07-30 A | 2011-07-30 A |  | 100% |  |  |  |  | finish on 2011-07-30 | TB26 - 3 - Construction Normal 7days * CA17 |  |  |  | 22t | XN753104 | 0 | 0 | 934 | 31 | 200 | 200 | C | LND | X | N | XN06 | 3120 | N | 31 | X | SS | LND | 3120 |  |  |  |  |  |  |  | SD |  |  |  | 27.8. |  |  |  |  |  |  |  | XNK |  |  |
| XN773104 |  | CA31 Warehouse SK3104_40 - Steel Deliveries (welded sections) | milestone | 0d | 2011-08-30 | 2011-08-30 |  |  |  |  | -29d | 13d | finish on 2011-08-30 | TB26 - 3 - Construction Normal 7days * CA17 |  |  |  | 22t | XN773104 | 0 | 0 | 934 | 31 | 200 | 200 | C | LND | X | N | XN06 | 3120 | N | 31 | X | SS | LND | 3120 |  |  |  |  |  |  |  | SD |  |  |  |  |  |  |  |  |  |  |  | XNK |  |  |
| XN203120 |  | CA31 Blower Sec SK3104 - Install Primary Steel |  | 43d | 2011-09-01 | 2011-10-20 | XC40312015, XN743104, XN713104, XN773104 FS-12d, XN703104, XN763104, XN753104, XN733104, XN723104, P3N02ZN (other project), XC40312020 SS+15d |  |  |  | -36d | 30d |  |  | Piperacks, Main Structures [230 t]; Piperacks, Main structures [9775 h] | 391,000 |  | 9775,00 | XN203120 | 9775 | 0 | 934 | 31 | 200 | 200 | C | LND | X | N | XN80 | 3120 | N | 31 | X | SS | LND | 3140 | OMUS-1 |  |  |  |  |  |  | C7 | CA16 - critical - CW05 |  |  | 27.8. | x |  | Check Roof - Cladding |  |  |  |  |  | 45>125 modified |  |
| XN803120 |  | CA31 Blower Sec SK3104 - Install Cladding |  | 80d | 2011-11-15 | 2012-02-22 | EN803120 (other project), XN203120 SS+15d, XC40312015, P3N03N (other project) |  |  |  | -84d | 0d | start on or after 2011-11-15 |  | Cladding [3020 sqm]; Cladding [15100 h] |  |  | 15100,00 | XN803120 | 15100 | 0 | 934 | 31 | 200 | 200 | C | LND | X | N | XN80 | 3120 | N | 31 | X | SS | LND | 3120 | OMUS-1 |  |  |  |  |  |  | C7 | CA16 - critical - CW05 |  |  |  |  |  | Check Roof - Cladding |  |  |  |  | XNK |  |  |
| XN303120 |  | CA31 Blower Sec SK3104 - Install Platforms |  | 30d | 2012-01-19 | 2012-02-22 | XB003120 SS+20d, XX-21501-BL01 SS+10d, EN803120 (other project), XX-22501-BL01 SS+10d, EN283100 (other project) FF, P3N02ZN (other project) FS+20d |  |  |  | -64d | 0d |  |  | Ladders & platforms [6 t]; Ladders & platforms [600 h] | 354.76 |  | 600,00 | XN303120 | 600 | 0 | 934 | 31 | 200 | 200 | C | LND | X | N | XN30 | 3120 | N | 31 | X | SS | LND | 3120 | OMUS-1 |  |  |  |  |  |  |  |  |  |  |  |  |  | Check Roof - Cladding |  |  |  |  | XNK |  | t |
| XN403120 |  | CA31 Blower Sec SK3104 - Install Railings,Ladders,etc. |  | 40d | 2012-02-11 | 2012-03-30 | XN303120 SS+20d |  |  |  | -64d | 0d |  |  | Ladders & platforms [6 t]; Ladders & platforms [600 h] | 103.47 |  | 600,00 | XN403120 | 600 | 0 | 934 | 31 | 200 | 200 | C | LND | X | N | XN40 | 3120 | N | 31 | X | SS | LND | 3120 | OMUS-1 |  |  |  |  |  |  |  |  |  |  |  |  |  | Check Roof - Cladding |  |  |  |  | XNK |  |  |
| XN603120 |  | CA31 Blower Sec SK3104 - Install Gratings |  | 20d | 2012-03-07 | 2012-03-30 | XN403120 FF, PN693120 (other project) |  |  |  | -64d | 20d |  |  | Grating [150 sqm]; Grating [562.5 h] | 206.94 |  | 562,50 | XN603120 | 562,5 | 0 | 934 | 31 | 200 | 200 | C | LND | X | N | XN60 | 3120 | N | 31 | X | SS | LND | 3120 | OMUS-1 |  |  |  |  |  |  |  |  |  |  |  |  |  | Check Roof - Cladding |  |  |  |  | XNK |  |  |

Notes:
- XW503110: P3 Activity Log Info: Clarification Surface Protection during Prefab
- XV303110: Current Status: 110315 (WL): Add PRED A1010100 CA31 SiloStruc - Install Conveying Eqpt / 110315 (WL): Delete PRED XE803110 CA31 SiloStruc - Install Heat / Tracing
- XC153120: P3 Activity Log Info: 600 driven piles expected, 20/d/machine
- XC40312015: Current Status: 110316 (WL): Delete PRED XC40311017 CA31 SiloStruc - Erection Precast / Elements
- XC303120: P3 Activity Log Info: Clarification Prefab / Catch Basins/pulling pits
- XC203120: Current Status: 19.02.2011 (O.Siegel): nicht beauftragt. (der ursprьngliche Fortschritt wurde / rausgenommen, da noch keine Arbeiten durchgefьrht worden sind)
- XC303125: P3 Activity Log Info: Clarification Prefab / Catch Basins/pulling pits
- XN713104: Scope: 09.02.2011: weight: 45 ton
- XN733104: Scope: 09.02.2011: weight:
- XN753104: Scope: 09.02.2011: weight:
- XN773104: Scope: 09.02.2011: weight: 80 ton
- XN803120: Current Status: 2110806 Delivery end of September 2011 (Info from Fr. Schilka 02.08.2011)

| ID | WBS | Activity | Type | Duration | Start | Finish | Predecessors | Total float | Free float | Resources | Cost | Filter | TB26 Ressource Budget | UDF_SELECT | UDF_CONTRACT START DATE | UDF_CONTRACT FINISH DATE | UDF_L3 START DATE | UDF_L3 FINISH DATE | UDF_SAVE ACT ID | UDF_BUDGETED LABOR UNIT | UDF_ACTUAL LABOR UNIT | Department | Type of Work | Constr. Area | PMT-Area | PMT-Schedule Org | PMT-Phase | PMT-Respons. | WBS Phase | WBS Discipline | WBS Type of Work | WBS Objects | Russia WBS Discipline (Russia) | Russia Construction Area | Russia WBS Phase | IMS | UPT | Russia WBS Objects | Subcontractor | Check ResLoading | UDF_CONTRACT ITEM | WEIGHT | UDF_LEVEL | UDF_TAG No | UDF_Object No | UDF_PACKAGE | Zeigen/n. Zeigen | UDF_Text4 | UDF_CONTRACT DATE PENALIZED | UDF_PENALIZED START | UDF_PENALIZED FINISH | Inquiry/Order No | UDF_Weight (ton) |
| --- | --- | --- | --- | --- | --- | --- | --- | --- | --- | --- | --- | --- | --- | --- | --- | --- | --- | --- | --- | --- | --- | --- | --- | --- | --- | --- | --- | --- | --- | --- | --- | --- | --- | --- | --- | --- | --- | --- | --- | --- | --- | --- | --- | --- | --- | --- | --- | --- | --- | --- | --- | --- | --- |
|  | H | **HVAC** |  |  | 2011-11-26 | 2012-05-18 |  |  |  |  |  |  |  |  |  |  |  |  |  |  |  |  |  |  |  |  |  |  |  |  |  |  |  |  |  |  |  |  |  |  |  |  |  |  |  |  |  |  |  |  |  |  |  |
| XH00312005 |  | CA31 Blower Sec - Installation HVAC |  | 90d | 2011-11-26 | 2012-03-19 | EH30312005 (other project), XH000000 FF, P3H01SR (other project), XN803120 SS+10d, XN203120, XC503120 SS+30d, XC503120_1 | 83d | 0d | HVAC - Warehouse CA31 [3658 mhr]; HVAC - Warehouse CA31 [3658 h] |  | x | 3658,00 | REL XC50 | 2011-06-20 | 2011-08-30 | 2011-07-08 | 2011-09-03 | XH00312005 | 3658 | 0 | 934 | XBB | 31 | 200 | 200 | C | LND | X | H | XH00 | 3100 | H | 31 | X | hvac | LND | 3120 | ARMO | 31 |  |  |  |  |  |  |  |  |  |  |  |  |  |
| XH00312010 |  | CA31 Blower Sec - Testing/Commissiong HVAC (Start w. temp. Power) |  | 70d | 2012-02-24 | 2012-05-18 | XH00312005 FS-20d, XH000C10, X0300008 FS+20d, X0300080 | 83d | 0d |  |  |  |  |  |  |  | 2011-08-11 | 2011-10-17 | XH00312010 | 0 | 0 | 934 | XBB | 31 | 200 | 200 | C | LND | X | H | XH20 | 3120 | H | 31 | X | hvac | LND | 3120 | ARMO |  |  |  |  |  |  |  |  |  |  |  |  |  |  |
| XH00312007 |  | CA31 Blower Sec - HVAC ready for Heating | milestone | 0d | 2012-03-07 | 2012-03-07 | XH00312010 SS+10d | 327.5d | 143.5d |  |  |  |  |  |  |  | 2011-08-23 | 2011-08-23 | XH00312007 | 0 | 0 | 934 | XBB | 31 | 200 | 200 | C | LND | X | H | XH00 | 3120 | H | 31 | X | hvac | LND | 3120 | ARMO |  | CM09 |  |  |  |  |  |  |  |  |  |  |  |  |
| XH00312006 |  | CA31 Blower Sec - Installation HVAC finished | milestone | 0d | 2012-03-19 | 2012-03-19 | XH00312005 FF | 86d | 181d |  |  |  |  |  | 2011-08-30 | 2011-08-30 | 2011-09-03 | 2011-09-03 | XH00312006 | 0 | 0 | 934 | XBB | 31 | 200 | 200 | C | LND | X | H | XH00 | 3120 | H | 31 | X | hvac | LND | 3120 | ARMO |  | CM09 |  |  |  |  |  |  |  |  |  |  |  |  |
|  | U | **Package Units** |  |  |  |  |  |  |  |  |  |  |  |  |  |  |  |  |  |  |  |  |  |  |  |  |  |  |  |  |  |  |  |  |  |  |  |  |  |  |  |  |  |  |  |  |  |  |  |  |  |  |  |
|  | B | **Mechanical - Stationary Equipment** |  |  | 2011-12-20 | 2012-03-30 |  |  |  |  |  |  |  |  |  |  |  |  |  |  |  |  |  |  |  |  |  |  |  |  |  |  |  |  |  |  |  |  |  |  |  |  |  |  |  |  |  |  |  |  |  |  |  |
| E-21504A/B/C |  | TRANSFER AIR COOLER |  | 30d | 2011-12-20 | 2012-01-30 | XB003120 SS | 357.5d |  | Static Equipment < 10 tons [2.37 t]; Static equipment < 10t [237 h] | 9,480 |  | 237,00 |  |  |  |  |  | E-21504A/B/C | 237 | 0 |  |  | 31 |  |  |  |  | X | B |  | 3120 |  |  |  |  |  |  | OMUS-1 |  |  | 790 | concrete +0.75 | E-21504A/B/C | SK3120 | PU10 CONVEYING SYSTEM (PK-21501) ZEPPELIN | EQ |  |  |  |  |  |  |
| E-21505A/B |  | TRANSFER AIR COOLER |  | 30d | 2011-12-20 | 2012-01-30 | XB003120 SS | 357.5d |  | Static Equipment < 10 tons [2.6 t]; Static equipment < 10t [260 h] | 10,400 |  | 260,00 |  |  |  |  |  | E-21505A/B | 260 | 0 |  |  | 31 |  |  |  |  | X | B |  | 3120 |  |  |  |  |  |  | OMUS-1 |  |  | 1300 | concrete +0.85 | E-21505A/B | SK3120 | PU10 CONVEYING SYSTEM (PK-21501) ZEPPELIN | EQ |  |  |  |  |  |  |
| E-21506A/B/C |  | TRANSFER AIR COOLER |  | 30d | 2011-12-20 | 2012-01-30 | XB003120 SS | 357.5d |  | Static Equipment < 10 tons [0.86 t]; Static equipment < 10t [86 h] | 3,440 |  | 86,00 |  |  |  |  |  | E-21506A/B/C | 86 | 0 |  |  | 31 |  |  |  |  | X | B |  | 3120 |  |  |  |  |  |  | OMUS-1 |  |  | 430 | concrete +0.70 | E-21506A/B/C | SK3120 | PU10 CONVEYING SYSTEM (PK-21501) ZEPPELIN | EQ |  |  |  |  |  |  |
| E-21507A/B |  | TRANSFER AIR COOLER |  | 30d | 2011-12-20 | 2012-01-30 | XB003120 SS | 357.5d |  | Static Equipment < 10 tons [0.43 t]; Static equipment < 10t [43 h] | 1,720 |  | 43,00 |  |  |  |  |  | E-21507A/B | 43 | 0 |  |  | 31 |  |  |  |  | X | B |  | 3120 |  |  |  |  |  |  | OMUS-1 |  |  | 430 | concrete +0.70 | E-21507A/B | SK3120 | PU10 CONVEYING SYSTEM (PK-21501) ZEPPELIN | EQ |  |  |  |  |  |  |
| F-21506A/B/C |  | TRANSFER AIR COOLER |  | 30d | 2011-12-20 | 2012-01-30 | XB003120 SS | 357.5d |  | Static Equipment < 10 tons; Static equipment < 10t |  |  | 0,00 |  |  |  |  |  | F-21506A/B/C | 0 | 0 |  |  | 31 |  |  |  |  | X | B |  | 3120 |  |  |  |  |  |  | OMUS-1 |  |  | 430 | concrete +0.70 | F-21506A/B/C | SK3120 | PU10 CONVEYING SYSTEM (PK-21501) ZEPPELIN | EQ |  |  |  |  |  |  |
| F-21507A/B |  | TRANSFER AIR INLET FILTER |  | 30d | 2011-12-20 | 2012-01-30 | XB003120 SS | 357.5d |  | Static Equipment < 10 tons [5.74 t]; Static equipment < 10t [574.5 h] | 22,960 |  | 0,00 |  |  |  |  |  | F-21507A/B | 574,5 | 0 |  |  | 31 |  |  |  |  | X | B |  | 3120 |  |  |  |  |  |  | OMUS-1 |  |  | 430 |  | F-21507A/B | SK3120 | PU10 CONVEYING SYSTEM (PK-21501) ZEPPELIN | EQ |  |  |  |  |  |  |
| XB003120 |  | CA31 Blower Sec - Install Static Eqpt |  | 80d | 2011-12-20 | 2012-03-30 | ER293100 (other project) FS+40d, XC603120, P3A13S3A (other project), XN803120 SS+30d, P3A06AS3 (other project) | -84d | 0d |  |  |  | 55 |  |  |  |  |  | XB003120 | 0 | 0 | 934 | XBB | 31 | 200 | 200 | C | LND | X | B | XB00 | 3120 | B | 31 | X | EQ | LND | 3120 | OMUS-1 |  | E-08-01-19 |  |  |  |  |  | C7 | CA16 - critical - CW05 | P | 2011-12-30 | 2011-12-30 |  |  |
|  | M | **Mechanical - Rotating Equipment** |  |  | 2011-12-20 | 2012-03-30 |  |  |  |  |  |  |  |  |  |  |  |  |  |  |  |  |  |  |  |  |  |  |  |  |  |  |  |  |  |  |  |  |  |  |  |  |  |  |  |  |  |  |  |  |  |  |  |
| K-21504A/B/C |  | TRANSFER AIR COMPRESSOR |  | 80d | 2011-12-20 | 2012-03-30 | XB003120 SS | 26d | 113.5d | Static Equipment < 10 tons [23.69 t]; Static equipment < 10t [2369.2 h] | 94,768 |  | 2369,20 |  |  |  |  |  | K-21504A/B/C | 2369,2 | 0 |  |  | 31 |  |  |  |  | X | B |  | 3120 |  |  |  |  |  |  | OMUS-1 |  |  | 5923 | concrete +0.30 | K-21504A/B/C | SK3120 | PU10 CONVEYING SYSTEM (PK-21501) ZEPPELIN | EQ |  |  |  |  |  |  |
| K-21505 A-E |  | TRANSFER AIR COMPRESSOR |  | 60d | 2011-12-20 | 2012-03-06 | XB003120 SS | 327.5d |  | Static Equipment < 10 tons [15.69 t]; Static equipment < 10t [1569 h] | 62,760 |  | 1569,00 |  |  |  |  |  | K-21505 A-E | 1569 | 0 |  |  | 31 |  |  |  |  | X | B |  | 3120 |  |  |  |  |  |  | OMUS-1 |  |  | 3138 | concrete +0.30 | K-21505 A-E | SK3120 | PU10 CONVEYING SYSTEM (PK-21501) ZEPPELIN | EQ |  |  |  |  |  |  |
| K-21506A/B/C |  | TRANSFER AIR COMPRESSOR |  | 60d | 2011-12-20 | 2012-03-06 | XB003120 SS | 327.5d |  | Static Equipment < 10 tons [14.55 t]; Static equipment < 10t [1455 h] | 58,200 |  | 1455,00 |  |  |  |  |  | K-21506A/B/C | 1455 | 0 |  |  | 31 |  |  |  |  | X | B |  | 3120 |  |  |  |  |  |  | OMUS-1 |  |  | 4850 | concrete +0.30 | K-21506A/B/C | SK3120 | PU10 CONVEYING SYSTEM (PK-21501) ZEPPELIN | EQ |  |  |  |  |  |  |
| K-21507A/B |  | TRANSFER AIR COMPRESSOR |  | 30d | 2011-12-20 | 2012-01-30 | XB003120 SS | 357.5d |  | Static Equipment < 10 tons [9.7 t]; Static equipment < 10t [970 h] | 38,800 |  | 970,00 |  |  |  |  |  | K-21507A/B | 970 | 0 |  |  | 31 |  |  |  |  | X | B |  | 3120 |  |  |  |  |  |  | OMUS-1 |  |  | 4850 | concrete +0.30 | K-21507A/B | SK3120 | PU10 CONVEYING SYSTEM (PK-21501) ZEPPELIN | EQ |  |  |  |  |  |  |
| K-21508 |  | TRANSFER AIR COMPRESSOR |  | 30d | 2011-12-20 | 2012-01-30 | XB003120 SS | 357.5d |  | Static Equipment < 10 tons [0.49 t]; Static equipment < 10t [49.5 h] | 1,980 |  | 49,50 |  |  |  |  |  | K-21508 | 49,5 | 0 |  |  | 31 |  |  |  |  | X | B |  | 3120 |  |  |  |  |  |  | OMUS-1 |  |  | 495 | concrete +0.30 | K-21508 | SK3120 | PU10 CONVEYING SYSTEM (PK-21501) ZEPPELIN | EQ |  |  |  |  |  |  |
| PK-21504 |  | BIG BAG FILLING STATION (downstr PK-21503) |  | 30d | 2011-12-20 | 2012-01-30 | XB003120 SS | 357.5d |  | Static Equipment < 10 tons; Static equipment < 10t |  |  | 0,00 |  |  |  |  |  | PK-21504 | 0 | 0 |  |  | 31 |  |  |  |  | X | B |  | 3120 |  |  |  |  |  |  | OMUS-1 |  |  | 2500 |  | PK-21504 | SK3120 | PU10 CONVEYING SYSTEM (PK-21501) ZEPPELIN | EQ |  |  |  |  |  |  |
| RF-21515-BL01 |  | CONTAINER LOADING FAN |  | 30d | 2011-12-20 | 2012-01-30 | XB003120 SS | 357.5d |  | Static Equipment < 10 tons [0.5 t]; Static equipment < 10t [50 h] | 2,000 |  | 50,00 |  |  |  |  |  | RF-21515-BL01 | 50 | 0 |  |  | 31 |  |  |  |  | X | B |  | 3120 |  |  |  |  |  |  | OMUS-1 |  |  | 500 | concrete +0.30 | RF-21515-BL01 | SK3120 | PU10 CONVEYING SYSTEM (PK-21501) ZEPPELIN | EQ |  |  |  |  |  |  |
| RF-21516-BL01 |  | CONTAINER LOADING FAN |  | 30d | 2011-12-20 | 2012-01-30 | XB003120 SS | 357.5d |  | Static Equipment < 10 tons [0.5 t]; Static equipment < 10t [50 h] | 2,000 |  | 50,00 |  |  |  |  |  | RF-21516-BL01 | 50 | 0 |  |  | 31 |  |  |  |  | X | B |  | 3120 |  |  |  |  |  |  | OMUS-1 |  |  | 500 | concrete +0.30 | RF-21516-BL01 | SK3120 | PU10 CONVEYING SYSTEM (PK-21501) ZEPPELIN | EQ |  |  |  |  |  |  |
| V-21505 A/B |  | TRANSFER AIR LIQUID SEPARATOR |  | 30d | 2011-12-20 | 2012-01-30 | XB003120 SS | 357.5d |  | Static Equipment < 10 tons [0.68 t]; Static equipment < 10t [68 h] | 2,720 |  | 68,00 |  |  |  |  |  | V-21505 A/B | 68 | 0 |  |  | 31 |  |  |  |  | X | B |  | 3120 |  |  |  |  |  |  | OMUS-1 |  |  | 2300 | concrete +0.15 | V-21505 A/B | SK3120 | PU10 CONVEYING SYSTEM (PK-21501) ZEPPELIN | EQ |  |  |  |  |  |  |
| V-21506 A/B |  | TRANSFER AIR LIQUID SEPARATOR |  | 30d | 2011-12-20 | 2012-01-30 | XB003120 SS | 357.5d |  | Static Equipment < 10 tons [0.23 t]; Static equipment < 10t [23 h] | 920 |  | 23,00 |  |  |  |  |  | V-21506 A/B | 23 | 0 |  |  | 31 |  |  |  |  | X | B |  | 3120 |  |  |  |  |  |  | OMUS-1 |  |  | 2300 | concrete +0.15 | V-21506 A/B | SK3120 | PU10 CONVEYING SYSTEM (PK-21501) ZEPPELIN | EQ |  |  |  |  |  |  |
| V-21507 A/B |  | TRANSFER AIR LIQUID SEPARATOR |  | 30d | 2011-12-20 | 2012-01-30 | XB003120 SS | 357.5d |  | Static Equipment < 10 tons [0.23 t]; Static equipment < 10t [23 h] | 920 |  | 23,00 |  |  |  |  |  | V-21507 A/B | 23 | 0 |  |  | 31 |  |  |  |  | X | B |  | 3120 |  |  |  |  |  |  | OMUS-1 |  |  | 2300 | concrete +0.15 | V-21507 A/B | SK3120 | PU10 CONVEYING SYSTEM (PK-21501) ZEPPELIN | EQ |  |  |  |  |  |  |
| XM103120 |  | CA31 Blower Sec - Install Convey.Compressors |  | 80d | 2011-12-20 | 2012-03-30 | XN803120 SS+30d, P3U10S3 (other project), XC603120 | -84d | 0d | Rotating Equipment (w/o lube oil unit) [2.54 t]; Rotating equipment (w/o lube oil unit) [253.8 h] | 8,890 |  | 238,10 |  |  |  |  |  | XM103120 | 253,8 | 0 | 934 |  | 31 | 200 | 200 | C | LND | X | M | XM10 | 3120 | M | 31 | X | EQ | LND | 3120 | OMUS-1 |  | E-08-01-19 |  |  |  |  |  | C7 | CA16 - critical - CW05 | P | 2011-12-30 | 2011-12-30 | 2DC8990 |  |
| XX-21501-BL01 |  | ELUTRIATOR FAN |  | 5d | 2011-12-20 | 2011-12-24 | XN803120 SS+30d, P3U10S2D (other project), XC603120, P3U10S2A (other project) | -84d | 0d | Static Equipment < 10 tons [2.3 t]; Static equipment < 10t [230 h] | 9,200 |  | 230,00 |  |  |  |  |  | XX-21501-BL01 | 230 | 0 |  |  | 31 |  |  |  |  | X | B |  | 3120 |  |  |  |  |  |  | OMUS-1 |  |  | 2300 | concrete +0.15 | XX-21501-BL01 | SK3120 | PU10 CONVEYING SYSTEM (PK-21501) ZEPPELIN | EQ |  |  |  |  |  | 2,3 |
| XX-22501-BL01 |  | ELUTRIATOR FAN |  | 5d | 2011-12-20 | 2011-12-24 | XC603120, XN803120 SS+30d, P3U10S2A (other project), XX-21501-BL01 SS, P3U10S2D (other project) | -84d | 0d | Static Equipment < 10 tons [2.3 t]; Static equipment < 10t [230 h] | 9,200 |  | 230,00 |  |  |  |  |  | XX-22501-BL01 | 230 | 0 |  |  | 31 |  |  |  |  | X | B |  | 3120 |  |  |  |  |  |  | OMUS-1 |  |  | 2300 | concrete +0.15 | XX-22501-BL01 | SK3120 | PU10 CONVEYING SYSTEM (PK-21501) ZEPPELIN | EQ |  |  |  |  |  | 2,3 |
| RF-21515 |  | BELT CONVEYER FOR REAR CONTAINER FILLING |  | 5d | 2012-01-09 | 2012-01-13 | P3U10S1A (other project), XN803120 SS+15d, MI-21501, XC603120 | 40d | 0d | Static Equipment < 10 tons [2.47 t]; Static equipment < 10t [247 h] | 9,880 |  | 247,00 |  |  |  |  |  | RF-21515 | 247 | 0 |  |  | 31 |  |  |  |  | X | B |  | 3120 |  |  |  |  |  |  | OMUS-1 |  |  | 2500 | concrete +0.30 | RF-21515 | SK3120 | PU10 CONVEYING SYSTEM (PK-21501) ZEPPELIN | EQ |  |  |  |  |  | 2,5 |
| RF-21516 |  | BELT CONVEYER FOR REAR CONTAINER FILLING |  | 5d | 2012-01-09 | 2012-01-13 | P3U10S1A (other project), MI-21501, XC603120, XN803120 SS+15d, RF-21515 SS | 40d | 124d | Static Equipment < 10 tons [2.5 t]; Static equipment < 10t [250 h] | 10,000 |  | 250,00 |  |  |  |  |  | RF-21516 | 250 | 0 |  |  | 31 |  |  |  |  | X | B |  | 3120 |  |  |  |  |  |  | OMUS-1 |  |  | 2500 | concrete +0.30 | RF-21516 | SK3120 | PU10 CONVEYING SYSTEM (PK-21501) ZEPPELIN | EQ |  |  |  |  |  | 2,5 |

| ID | WBS | Activity | Duration | Start | Finish | Predecessors | Complete | Remaining | Total float | Free float | Calendar | Resources | Cost | Actual cost | TB26 Ressource Budget | UDF_CONTRACT INDICATOR | UDF_SELECT UPDATE PROGRESS | UDF_SAVE ACT ID | UDF_BUDGETED LABOR UNIT | UDF_ACTUAL LABOR UNIT | UDF_CHECK RESOURCE DATES | Department | Constr. Area | PMT-Area | PMT-Schedule Org | PMT-Phase | PMT-Respons. | WBS Phase | WBS Discipline | WBS Type of Work | WBS Objects | Russia WBS Discipline (Russia) | Russia Construction Area | Russia WBS Phase | IMS | UPT | Russia WBS Objects | Subcontractor | UDF_Text4 | UDF_CONTRACT ITEM | UDF_PLANNED START | Zeigen/n. Zeigen | UDF_PLANNED FINISH | UDF_CONTRACT START DATE | UDF_CONTRACT FINISH DATE | UDF_CONTRACT FINISH DATE REV1 | UDF_CONTRACT START DATE REV1 | UDF_INDICATOR | TB26 Semantics | TB26 Material Res Values | UDF_ELECTRICAL START | UDF_ELECTRICAL FINISH | UDF_CHECK BASELINE | UDF_COMMENTS_0827 | Filter | UDF_Vendor Representatives | geplanter Start | geplantes Ende | UDF_PENALIZED FINISH |
| --- | --- | --- | --- | --- | --- | --- | --- | --- | --- | --- | --- | --- | --- | --- | --- | --- | --- | --- | --- | --- | --- | --- | --- | --- | --- | --- | --- | --- | --- | --- | --- | --- | --- | --- | --- | --- | --- | --- | --- | --- | --- | --- | --- | --- | --- | --- | --- | --- | --- | --- | --- | --- | --- | --- | --- | --- | --- | --- | --- |
|  | R | **Piping** |  | 2011-05-26 | 2012-06-23 |  |  |  |  |  |  |  |  |  |  |  |  |  |  |  |  |  |  |  |  |  |  |  |  |  |  |  |  |  |  |  |  |  |  |  |  |  |  |  |  |  |  |  |  |  |  |  |  |  |  |  |  |  |  |
| XR203120 |  | CA31 Blower Sec - Piping Prefabrication | 155d | 2011-05-26 A | 2011-11-24 | P3U10S1A (other project), ER49312005 (other project) SS+18d, XR200C10 SS+60d, ER493120 (other project) SS+18d |  | 76d | 13d | 131d |  | A/G piping prefabrication [760 Fpi]; Conveying S. piping prefabrication [4600 Fpi]; A/G Piping (Prefab) [2850 h]; Conveying system (Prefab) [11500 h] | 470,794.38 | 127,612.9 | 14350,00 | UDF_G4 | 27.8. | XR203120 | 14350 | 2035 | x | 934 | 31 | 200 | 200 | C | LND | X | R | XR20 | 3120 | R | 31 | X | PRP | LND | 3120 | OMUS-1 |  |  |  |  |  |  |  |  |  |  |  |  |  |  |  |  |  |  |  |  |  |
| XR403120 |  | CA31 Blower Sec - Piping Installation | 120d | 2011-12-20 | 2012-05-18 | XB003120 SS, XR203120 SS+50d, XM103120 SS, XX-22501-BL01 SS, P3S07S (other project) FF+20d, XN603120 FF+20d, P3J04CS1 (other project) FF, XR203120 FF+10d, P3J04IS (other project), XX-21501-BL01 SS |  |  | -84d | 0d |  | A/G piping field installation [930 Fpi]; Conveying S. piping field installation [4000 Fpi]; Control & Shut-off valves [14 pcs]; A/G Piping (Field) [5812.5 h]; Conveying system (Field) [20000 h]; Install Control & Shut-off Valves [73.5 h]; Deluge Piping [4000 Fpi]; Deluge piping [25000 h] | 1,641,313.45 |  | 50886,00 |  |  | XR403120 | 50886 | 0 |  | 934 | 31 | 200 | 200 | C | LND | X | R | XR40 | 3120 | R | 31 | X | PI | LND | 3120 | OMUS-1 | CA16 - critical - CW05 | E-06-03-08 | 2011-06-28 | C7 |  |  |  |  |  |  |  |  |  |  |  |  |  |  |  |  |  |
| XR603120 |  | CA31 Blower Sec - Piping Pressure Tests | 70d | 2012-03-20 | 2012-06-11 | XR403120 FF+20d |  |  | -84d | 0d |  |  |  |  | 638 |  |  | XR603120 | 0 | 0 |  | 934 | 31 | 200 | 200 | C | LND | X | R | XR60 | 3120 | R | 31 | X | HY | LND | 3120 | OMUS-1 | CA16 - critical - CW05 | E-06-03-08 |  | C7 |  |  |  |  |  |  |  |  |  |  |  |  |  |  |  |  |  |
| XR803120 |  | CA31 Blower Sec - Piping Reinstatement | 30d | 2012-05-19 | 2012-06-23 | XR603120 FF+10d, IMS-C-000360 FF |  |  | -84d | 0d |  |  |  |  | 319 |  |  | XR803120 | 0 | 0 |  | 934 | 31 | 200 | 200 | C | LND | X | R | XR80 | 3120 | R | 31 | X | PI | LND | 3120 | OMUS-1 | CA16 - critical - CW05 | E-06-03-08 |  | C7 | 2012-05-28 |  |  |  |  |  |  |  |  |  |  |  |  |  |  |  |  |
|  | E | **Electrical** |  | 2010-06-23 | 2012-10-11 |  |  |  |  |  |  |  |  |  |  |  |  |  |  |  |  |  |  |  |  |  |  |  |  |  |  |  |  |  |  |  |  |  |  |  |  |  |  |  |  |  |  |  |  |  |  |  |  |  |  |  |  |  |  |
| XC913120 |  | CA31 Blower Sec - Install Earthing&Lightn.System_CIVIL | 78d | 2010-06-23 A | 2010-09-21 A | EE903120 (other project), XC403120 SS | 100% |  |  |  |  | Grounding & Lightning [430 pcs]; Grounding & Lightning [4837.5 h] | 193,500 | 193,500 | 4837,50 |  |  | XC913120 | 4837,5 | 4837,5 |  | 934 | 31 | 200 | 200 | C | LND | X | C | XE91 | 3120 | C | 31 | X | EA | LND | 3120 | MO11 |  | E-16-07-12 |  |  |  | 2011-07-20 | 2012-01-30 |  |  |  |  |  |  |  |  |  |  |  |  |  |  |
| XE913120 |  | CA31 Blower Sec - Install Earthing&Lightn.System_E/I | 15d | 2012-02-24 | 2012-03-13 | XN803120 SS, XN303120 |  |  | 91d | 186d |  |  |  |  | 475 |  |  | XE913120 | 0 | 0 |  | 934 | 31 | 200 | 200 | C | LND | X | E | XE91 | 3120 | E | 31 | X | EA | LND | 3120 | URMA |  | E-16-07-12 |  |  |  | 2011-07-20 | 2012-01-30 | 2012-04-30 | 2011-10-01 | UDF_G2 |  |  |  |  |  |  |  |  |  |  |  |
| XE403120 |  | CA31 Blower Sec - Install Cable Trays | 50d | 2012-03-07 | 2012-05-05 | EE46312010 (other project), XN803120 SS+20d, XR403120 FS-60d |  |  | -24d | 0d |  | Cable trays/conduits [1840 m]; Cable trays [5520 h] | 220,800 |  | 5520,00 |  |  | XE403120 | 5520 | 0 |  | 934 | 31 | 200 | 200 | C | LND | X | E | XE40 | 3120 | E | 31 | X | EL | LND | 3120 | URMA |  | E-15-01-13 |  |  |  | 2011-06-30 | 2011-10-30 | 2012-02-15 | 2011-10-01 | UDF_G2 | m | 1950 | 2011-08-30 | 2011-11-08 | x | to be checked |  |  |  |  |  |
| XE343120 |  | CA31 Blower Sec - Install Local Operation Panels | 50d | 2012-04-06 | 2012-06-05 | EE46312010 (other project), XE403120 FS-25d, XR403120 FS-60d |  |  | 252.5d |  |  | Field Panels [27 pcs]; Field panels [540 h] | 21,600 |  | 540,00 |  |  | XE343120 | 540 | 0 |  | 934 | 31 | 200 | 200 | C | LND | X | E | XE34 | 3120 | E | 31 | X | EL | LND | 3120 | URMA |  | E-16-07-12 |  |  |  | 2011-07-20 | 2012-01-30 | 2012-04-30 | 2011-10-01 | UDF_G2 |  |  |  |  |  | to be checked |  |  |  |  |  |
| XE703120 |  | CA31 Blower Sec - Install Lighting & Small Power | 60d | 2012-04-18 | 2012-06-29 | EE763120 (other project), XP341610 FS+50d, XC603120, XN803120, P3E09S (other project), P3E03S2 (other project), XE403120 FS-20d, XC503120 FS+20d |  |  | 1d | 0d |  | Cable Pulling [3000 m]; Lighting illuminates [230 pcs]; Lighting (iluminates) [2300 h]; Cable pulling [1500 h] | 152,000 |  | 3800,00 |  |  | XE703120 | 3800 | 0 |  | 934 | 31 | 200 | 200 | C | LND | X | E | XE70 | 3120 | E | 31 | X | EL | LND | 3120 | URMA |  | E-16-03-01 |  |  |  | 2011-05-10 | 2012-01-31 | 2012-05-10 | 2011-08-15 | UDF_G2 |  |  |  |  |  |  | x |  |  |  |  |
| XE803120 |  | CA31 Blower Sec - Install Heat Tracing | 40d | 2012-04-30 | 2012-06-18 | E3E1950 (other project), P3E19S (other project), XR403120 FS-60d, XR603120 FS-35d |  |  | 11d | 27d |  | Electrical Heat Tracing [200 m]; Electrical heat tracing [100 h] | 4,000 |  | 100,00 |  | 27.8. | XE803120 | 100 | 0 |  | 934 | 31 | 200 | 200 | C | LND | X | E | XE80 | 3120 | E | 31 | X | HT | LND | 3120 | URMA |  | E-16-04-01 |  |  |  | 2011-06-20 | 2012-03-20 | 2012-06-30 | 2011-09-15 | UDF_G2 |  |  |  |  |  | will be installed later |  | 005 |  |  |  |
| XE923120 |  | CA31 Blower Sec - Install Fire Detection System | 50d | 2012-06-30 | 2012-08-27 | XH00312005, XC503120, XJ423120, XE703120 |  |  | 182.5d |  |  | Fire Detection System; Fire detection system |  |  | 0,00 |  |  | XE923120 | 0 | 0 |  | 934 | 31 | 200 | 200 | C | UIO | X | E | XE92 | 3120 | E | 31 | X | FGDS | LND | 3120 |  |  |  |  |  |  |  |  |  |  | UDF_G3 |  |  |  |  | x |  | x |  | 2012-02-14 | 2012-06-27 |  |
| XE963120 |  | CA31 Blower Sec - Install Communication System | 50d | 2012-06-30 | 2012-08-27 | XC503120, P3E13S (other project), XH00312005, XE703120, XJ423120 |  |  | 182.5d |  |  | Communication System |  |  | 0,00 |  |  | XE963120 | 0 | 0 |  | 934 | 31 | 200 | 200 | C | LND | X | E | XE96 | 3120 | E | 31 | X | CS | LND | 3120 |  |  |  |  |  |  |  |  |  |  | UDF_G3 |  |  |  |  | x |  | x |  | 2012-02-14 | 2012-06-27 |  |
| XE503120 |  | CA31 Blower Sec - Cable Pulling Electric | 60d | 2012-07-10 | 2012-09-18 | XE403120 FS-20d, XE505601 FS-20d, XE500C01, P3E15BS (other project), P3E15AS (other project), XE503130 FS-20d, P3E15CS (other project), EE563120 (other project) |  |  | -87.5d | 0d | TB26 - V - Construct-Winter partly * | Cable Pulling [9200 m]; Cable pulling [4600 h] | 184,000 |  | 4600,00 |  |  | XE503120 | 4600 | 0 |  | 934 | 31 | 200 | 200 | C | LND | X | E | XE50 | 3120 | E | 31 | X | EL | LND | 3120 | URMA |  | E-16-01-01 |  |  |  | 2011-05-20 | 2012-02-10 | 2012-07-01 | 2011-10-01 | UDF_G2 | m | 2300 | 2011-12-21 | 2012-03-07 |  |  |  |  |  |  |  |
| XE603120 |  | CA31 Blower Sec - Cable Termination & Testing | 50d | 2012-08-14 | 2012-10-11 | XE600C00 FF+20d, XE503120 FS-30d, K-21504A/B/C |  |  | -87.5d | 0d |  | Cable connecting [210 pcs]; Cable connecting [525 h] | 21,000 |  | 525,00 |  |  | XE603120 | 525 | 0 |  | 934 | 31 | 200 | 200 | C | LND | X | E | XE60 | 3120 | E | 31 | X | ET | LND | 3120 | URMA |  | E-16-02-01 |  |  |  | 2011-04-20 | 2011-11-30 | 2012-08-14 | 2011-12-10 | UDF_G2 |  |  |  |  |  |  |  |  |  |  |  |
|  | J | **Instrumentation** |  | 2012-03-07 | 2012-11-10 |  |  |  |  |  |  |  |  |  |  |  |  |  |  |  |  |  |  |  |  |  |  |  |  |  |  |  |  |  |  |  |  |  |  |  |  |  |  |  |  |  |  |  |  |  |  |  |  |  |  |  |  |  |  |
| XJ323120 |  | CA31 Blower Sec - Install Junction Boxes | 30d | 2012-03-07 | 2012-04-11 | EJ323120 (other project), P3J06ES (other project) FS+14d, XR403120 FS-60d, XN803120 |  |  | -19d | 5d |  | Junction Boxes/Cabinets/Panels [37 pcs]; Install Junction Boxes/ Cabinets/ Panels [925 h] | 37,000 |  | 925,00 |  | 27.8. | XJ323120 | 925 | 0 |  | 934 | 31 | 200 | 200 | C | LND | X | J | XJ32 | 3120 | J | 31 | X | IN | LND | 3120 | URMA |  | E-17-04-12 |  |  |  | 2011-07-20 | 2012-04-10 | 2012-07-10 | 2011-10-15 | UDF_G2 |  |  |  |  |  | will be installed later |  |  |  |  |  |
| XJ423120 |  | CA31 Blower Sec - Install Secondary Cable Trays | 40d | 2012-04-06 | 2012-05-24 | XJ323120 FS-10d, EJ46312010 (other project), XE403120 FS-25d, XR403120 FS-60d |  |  | -24d | 1.5d |  | Secondary cable trays [430 m]; Install secondary cable trays [1612.5 h] | 64,500 |  | 1612,50 |  |  | XJ423120 | 1612,5 | 0 |  | 934 | 31 | 200 | 200 | C | LND | X | J | XJ42 | 3120 | J | 31 | X | IN | LND | 3120 | URMA |  | E-15-01-13 |  |  |  | 2011-06-30 | 2011-10-30 | 2012-02-15 | 2011-10-01 | UDF_G2 | m | 650 | 2011-08-30 | 2011-11-08 | x |  | x |  |  |  |  |
| XJ443120 |  | CA31 Blower Sec - Install Conduits to Instrm | 40d | 2012-04-06 | 2012-05-24 | XJ323120 FS-10d, XE403120 FS-25d, XR403120 FS-60d |  |  | -19d | 65d |  |  |  |  |  |  |  | XJ443120 | 0 | 0 |  | 934 | 31 | 200 | 200 | C | LND | X | J | XJ44 | 3120 | J | 31 | X | IN | LND | 3120 | URMA |  | E-17-04-12 |  |  |  | 2011-07-20 | 2012-04-10 | 2012-07-10 | 2011-10-15 | UDF_G2 |  |  |  |  |  | will be installed later |  |  |  |  |  |
| XJ303120 |  | CA31 Blower Sec - Install Field Instruments | 60d | 2012-06-13 | 2012-08-21 | XR403120 FS-60d, EJ363120 (other project), P3J05S (other project), XR803120 FS-10d, RF-21516 |  |  | -84d | 0d |  | Field Instruments [51 pcs]; Install field instruments [281 h] | 11,220 |  | 281,00 |  | 27.8. | XJ303120 | 281 | 0 |  | 934 | 31 | 200 | 200 | C | LND | X | J | XJ30 | 3120 | J | 31 | X | IN | LND | 3120 | URMA | CA16 - critical - CW05 | E-17-04-12 |  | C7 |  | 2011-07-20 | 2012-04-10 | 2012-07-10 | 2011-10-15 | UDF_G2 |  |  |  |  |  | will be installed later |  |  |  |  |  |
| XJ393120 |  | CA31 Blower Sec - Install Earthing Field Eqpt | 40d | 2012-07-18 | 2012-09-01 | XJ303120 FS-30d, XJ423120 FS-20d, XJ443120 FS-20d |  |  | -84d | 0d |  |  |  |  |  |  |  | XJ393120 | 0 | 0 |  | 934 | 31 | 200 | 200 | C | LND | X | J | XJ39 | 3120 | J | 31 | X | IN | LND | 3120 | URMA |  | E-17-04-12 |  |  |  | 2011-07-20 | 2012-04-10 | 2012-07-10 | 2011-10-15 | UDF_G2 |  |  |  |  |  | will be installed later |  |  |  |  |  |
| XJ543120 |  | CA31 Blower Sec - Pulling Singlecore Cables | 40d | 2012-07-18 | 2012-09-01 | XJ303120 FS-30d, XJ423120 FS-20d, XJ443120 FS-20d, XE500C01, EJ803120 (other project) |  |  | -84d | 0d | TB26 - V - Construct-Winter partly * | Singlecore cables [3500 m]; Pull singlecore cables [2625 h] | 105,000 |  | 2625,00 |  |  | XJ543120 | 2625 | 0 |  | 934 | 31 | 200 | 200 | C | LND | X | J | XJ54 | 3120 | J | 31 | X | IN | LND | 3120 | URMA | CA16 - critical - CW05 | E-17-04-12 |  | C7 |  | 2011-07-20 | 2012-04-10 | 2012-07-10 | 2011-10-15 | UDF_G2 | m | 3383 | 2012-01-20 | 2012-03-07 |  |  |  |  |  |  |  |
| XJ703120 |  | CA31 Blower Sec - Instrument Tubing | 40d | 2012-07-18 | 2012-09-01 | XJ303120 FS-30d |  |  | -84d | 0d |  |  |  |  |  |  |  | XJ703120 | 0 | 0 |  | 934 | 31 | 200 | 200 | C | LND | X | J | XJ70 | 3120 | J | 31 | X | IN | LND | 3120 | URMA |  | E-17-04-12 |  |  |  | 2011-07-20 | 2012-04-10 | 2012-07-10 | 2011-10-15 | UDF_G2 |  |  |  |  |  | will be installed later |  |  |  |  |  |
| XJ523120 |  | CA31 Blower Sec - Pulling Multicore Cables | 40d | 2012-07-27 | 2012-09-12 | XJ323120 FS-10d, XJ525601 FS-10d, XJ523130 FS-30d, XE500C01, XE403120 FS-25d |  |  | -65.5d | 0d | TB26 - V - Construct-Winter partly * | Multicore cables [3500 m]; Pull multicore cables [1750 h] | 70,000 |  | 1750,00 |  |  | XJ523120 | 1750 | 0 |  | 934 | 31 | 200 | 200 | C | LND | X | J | XJ52 | 3120 | J | 31 | X | IN | LND | 3120 | URMA |  | E-17-01-01 |  |  |  | 2011-05-20 | 2012-03-10 | 2012-06-16 | 2011-11-01 | UDF_G2 | m | 2550 | 2011-12-21 | 2012-02-11 |  |  |  |  |  |  |  |
| XJ643120 |  | CA31 Blower Sec - Termin Singlecore Cables | 50d | 2012-08-10 | 2012-10-06 | XJ543120 FS-20d, XJ323120 FS-10d, XJ393120 FS-20d, XJ703120 FS-20d |  |  | -84d | 3.5d |  | Termination Field [2117 mhr]; Termination field [2117 h] | 211,700 |  | 2117,00 |  |  | XJ643120 | 2117 | 0 |  | 934 | 31 | 200 | 200 | C | LND | X | J | XJ64 | 3120 | J | 31 | X | IN | LND | 3120 | URMA | CA16 - critical - CW05 | E-17-04-12 |  | C7 |  | 2011-07-20 | 2012-04-10 | 2012-07-10 | 2011-10-15 | UDF_G2 |  |  |  |  |  |  |  |  |  |  |  |
| XJ623120 |  | CA31 Blower Sec - Termin Multicore Cables | 40d | 2012-08-20 | 2012-10-05 | XJ523120 FS-20d, XH00312005 FS-20d, XJ323120 FS-10d |  |  | -65.5d | 0d |  | Termination Field [2118 mhr]; Termination field [2118 h] | 211,800 |  | 2118,00 |  |  | XJ623120 | 2118 | 0 |  | 934 | 31 | 200 | 200 | C | LND | X | J | XJ62 | 3120 | J | 31 | X | IN | LND | 3120 | URMA |  | E-17-01-01 |  |  |  | 2011-05-20 | 2012-03-10 | 2012-06-16 | 2011-11-01 | UDF_G2 |  |  |  |  |  |  |  |  |  |  |  |
| XJ803130 |  | CA31 Service Area - Inspections/ Mech. Acceptance/ Loop Checks | 50d | 2012-08-29 | 2012-10-25 | XJ2031305, X030410030, X3J120, XJ800C00 SS, XE50313020, XJ613130 FS-45d, XJ523130 FS-30d, XE503130, XJ513130, XE203130, XJ393130 |  |  | -53d | 17.5d |  |  |  |  | 1050,00 |  |  | XJ803120 | 1050 | 0 |  | 934 | 31 | 200 | 200 | C | LND | X | J | XJ80 | 3130 | J | 31 | X | LT | LND | 3130 | URMA | CA16 - critical - CW05 | E-17-02-01 |  | C7 |  | 2011-06-10 | 2012-04-30 | 2012-08-18 | 2012-03-01 | UDF_G2 |  |  |  |  |  |  |  |  |  |  | 2012-08-18 |
| XJ803120 |  | CA31 Blower Sec - Inspections/ Mech. Acceptance/ Loop Checks | 50d | 2012-09-12 | 2012-11-10 | X3J120, XJ800C00, XJ643120 FS-25d, XJ703120 FS-20d, XE603120 FS-25d, X030410030, EJ803120 (other project), XJ393120 FS-20d, XJ623120 FS-20d |  |  | -65.5d | 5d |  | Loop Checks [210 pcs]; Loop checks [1050 h] | 42,000 |  | 1050,00 |  |  | XJ803120 | 1050 | 0 |  | 934 | 31 | 200 | 200 | C | LND | X | J | XJ80 | 3120 | J | 31 | X | LT | LND | 3120 | URMA | CA16 - critical - CW05 | E-17-02-01 |  | C7 |  | 2011-06-10 | 2012-04-30 | 2012-08-18 | 2012-03-01 | UDF_G2 |  |  |  |  |  |  |  |  |  |  | 2012-08-18 |

Notes:
- XR403120: P3 Activity Log Info: Start with Fire Water / System
- XE913120: UDF_PREDECESSOR: XN30, DEL XE40, DEL XE80, DEL XJ40, Civil 100%, Equipment 100%
- XE403120: Current Status: 21.01.2011 Volkmann Change Start Cladding to SS Platforms / + 20 (scaffolding necessary) / UDF_PREDECESSOR: XN30, Piping 50%
- XE343120: UDF_PREDECESSOR: XE40, Equipment 100%, Piping 50%
- XE703120: UDF_PREDECESSOR: XE40, Civil 100%, HVAC ducts, Finishing works partly
- XE803120: UDF_PREDECESSOR: XR40, Piping 50% pressure tests
- XE923120: Scope: CA31: / FDS - 146external sensors / Structured Cable System (SCS) / FOCL / DS + SAME / MDCN
- XE963120: Scope: CA31: / FDS - 146external sensors / Structured Cable System (SCS) / FOCL / DS + SAME / MDCN
- XE503120: UDF_PREDECESSOR: XE40, XE50, DEL XE34
- XE603120: UDF_PREDECESSOR: XE50, Equipment 100%
- XJ323120: UDF_PREDECESSOR: Civil 100%, Equipment 100%, Piping 50%
- XJ423120: UDF_PREDECESSOR: XE40, XJ32, Equipment 100%, Piping 50%
- XJ443120: UDF_PREDECESSOR: XE40, XJ32, XJ40, Equipment 100%, Piping 50%
- XJ303120: UDF_PREDECESSOR: XR80, XR40, Equipment 100%, Piping 50%
- XJ393120: UDF_PREDECESSOR: XJ30, XJ42, XJ44, DEL XJ32, DEL XR40
- XJ543120: UDF_PREDECESSOR: XJ30, XJ42, XJ44
- XJ703120: UDF_PREDECESSOR: XJ30
- XJ523120: UDF_PREDECESSOR: XE40, XJ32, XJ52
- XJ643120: UDF_PREDECESSOR: XJ30, XJ32, XJ39, XJ54, XJ70
- XJ623120: UDF_PREDECESSOR: XJ32, XJ52
- XJ803130: UDF_PREDECESSOR: XE60, XJ39, XJ62, XJ64, XJ70
- XJ803120: UDF_PREDECESSOR: XE60, XJ39, XJ62, XJ64, XJ70

| ID | WBS | Activity | Type | Duration | Start | Finish | Predecessors | Complete | Remaining | Planned start | Planned finish | Total float | Free float | Constraint | Calendar | Resources | Cost | Actual cost | TB26 Ressource Budget | UDF_SELECT UPDATE PROGRESS | UDF_SAVE ACT ID | UDF_BUDGETED LABOR UNIT | UDF_ACTUAL LABOR UNIT | UDF_CHECK RESOURCE DATES | Department | Constr. Area | PMT-Area | PMT-Schedule Org | PMT-Phase | PMT-Respons. | WBS Phase | WBS Discipline | WBS Type of Work | WBS Objects | Russia WBS Discipline (Russia) | Russia Construction Area | Russia WBS Phase | IMS | UPT | Russia WBS Objects | Subcontractor | UDF_CONTRACT ITEM | UDF_CONTRACT DATE PENALIZED | UDF_PENALIZED START | UDF_PENALIZED FINISH | Zeigen/n. Zeigen | UDF_Text4 | UDF_CONTRACT INDICATOR | Comments | UDF_EXPECTED START | UDF_EXPECTED FINISH | UDF_Concrete | UDF_BASELINE DEVELOPMENT | Filter | UDF_SELECT | Check ResLoading | UDF_CHECK BASELINE | Type of Work | UDF_CHECK CRITICAL PATH | TB26 Semantics |
| --- | --- | --- | --- | --- | --- | --- | --- | --- | --- | --- | --- | --- | --- | --- | --- | --- | --- | --- | --- | --- | --- | --- | --- | --- | --- | --- | --- | --- | --- | --- | --- | --- | --- | --- | --- | --- | --- | --- | --- | --- | --- | --- | --- | --- | --- | --- | --- | --- | --- | --- | --- | --- | --- | --- | --- | --- | --- | --- | --- | --- |
|  | S | **Safety & Environment** |  |  |  |  |  |  |  |  |  |  |  |  |  |  |  |  |  |  |  |  |  |  |  |  |  |  |  |  |  |  |  |  |  |  |  |  |  |  |  |  |  |  |  |  |  |  |  |  |  |  |  |  |  |  |  |  |  |  |
|  | W | **Painting** |  |  | 2011-07-25 | 2012-01-30 |  |  |  |  |  |  |  |  |  |  |  |  |  |  |  |  |  |  |  |  |  |  |  |  |  |  |  |  |  |  |  |  |  |  |  |  |  |  |  |  |  |  |  |  |  |  |  |  |  |  |  |  |  |  |
| XW503120 |  | CA31 Blower Sec - Surf.Protection Piping |  | 105d | 2011-07-25 A | 2012-01-30 | XR403120 SF+30d |  | 76d | 2011-07-25 | 2011-11-24 | 357.5d |  |  |  | Piping painting [804 sqm]; Piping painting [2010 h] | 80,400 | 33,308.57 | 2010,00 | 27.8. | XW503120 | 2010 | 0 | x | 934 | 31 | 200 | 200 | C | LND | X | W | XW50 | 3120 | W | 31 | X | PA | LND | 3120 | OMUS-1 |  |  |  |  |  |  |  |  |  |  |  |  |  |  |  |  |  |  |  |
|  | V | **Insulation** |  |  | 2012-03-31 | 2012-07-31 |  |  |  |  |  |  |  |  |  |  |  |  |  |  |  |  |  |  |  |  |  |  |  |  |  |  |  |  |  |  |  |  |  |  |  |  |  |  |  |  |  |  |  |  |  |  |  |  |  |  |  |  |  |  |
| XV303120 |  | CA31 Blower Sec - Insulation Equipment |  | 80d | 2012-03-31 | 2012-07-05 | XM103120 |  |  |  |  | 37d | 16d |  |  | Equipment insulation [350 sqm]; Equipment insulation [4375 h] | 846.99 |  | 4375,00 |  | XV303120 | 4375 | 0 |  | 934 | 31 | 200 | 200 | C | LND | X | V | XV30 | 3120 | V | 31 | X | INS | LND | 3120 | OMUS-1 | E-13-03 | P | 2012-03-30 | 2012-03-30 |  |  |  |  |  |  |  |  |  |  |  |  |  |  |  |
| XV503120 |  | CA31 Blower Sec - Insulation Piping |  | 100d | 2012-04-03 | 2012-07-31 | XE803120 FF+10d, XR603120 SS+12d, XV303120 FF+6d |  |  |  |  | 21d | 91.5d |  |  | Piping insulation [1000 sqm]; Piping insulation [7500 h] | 3,382.07 |  | 7500,00 |  | XV503120 | 7500 | 0 |  | 934 | 31 | 200 | 200 | C | LND | X | V | XV50 | 3120 | V | 31 | X | INS | LND | 3120 | OMUS-1 | E-13-01 | P | 2012-04-30 | 2012-04-30 |  |  |  |  |  |  |  |  |  |  |  |  |  |  |  |
|  | 30 | **CA31(3104) - Service Area** |  |  | 2009-12-12 | 2012-10-19 |  |  |  |  |  |  |  |  |  |  |  |  |  |  |  |  |  |  |  |  |  |  |  |  |  |  |  |  |  |  |  |  |  |  |  |  |  |  |  |  |  |  |  |  |  |  |  |  |  |  |  |  |  |  |
|  | 0B | **General Activities** |  |  |  |  |  |  |  |  |  |  |  |  |  |  |  |  |  |  |  |  |  |  |  |  |  |  |  |  |  |  |  |  |  |  |  |  |  |  |  |  |  |  |  |  |  |  |  |  |  |  |  |  |  |  |  |  |  |  |
|  | C | **Civil Work** |  |  | 2009-12-12 | 2012-06-18 |  |  |  |  |  |  |  |  |  |  |  |  |  |  |  |  |  |  |  |  |  |  |  |  |  |  |  |  |  |  |  |  |  |  |  |  |  |  |  |  |  |  |  |  |  |  |  |  |  |  |  |  |  |  |
| XC153130 |  | CA31 Service Area - Piling outside SiloStructure |  | 58d | 2009-12-12 A | 2010-02-17 A | F2910, EC153130 (other project) FS+15d, IMS-C-000010 FF, XC11310005 FF | 100% |  |  |  |  |  |  |  | Piles driven [373 pcs]; Piles driven [2797.5 h] | 111,900 | 111,900 | 2797,50 |  | XC153130 | 2797,5 | 2797,5 |  | 934 | 31 | 200 | 200 | C | MO01 | X | C | XC15 | 3130 | C | 31 | X | P | LND | 3130 | MO11 |  |  |  |  |  |  |  |  |  |  |  |  |  |  |  |  |  |  |  |
| XC40313010 |  | CA31 Service Area SK3103 - Precast Concrete Elements |  | 78d | 2011-04-21 A | 2011-07-15 A | EC48313006 (other project), XCC02D2, EC48313004 (other project), P3C02D3 (other project) FF, EC48313008 (other project) FF | 100% |  | 2011-04-21 | 2011-07-23 |  |  |  |  |  |  |  |  |  | XC40313010 | 0 | 0 |  | 934 | 31 | 200 | 200 | C | MO04 | X | C | XC40 | 3130 | C | 31 | X | pre | LND | 3130 | MO11 |  |  |  |  | D |  |  |  |  |  |  |  |  |  |  |  |  |  |  |
| XC40313015 |  | CA31 Service Area SK3103 - Erection Precast Elements |  | 51d | 2011-07-04 A | 2011-08-26 A | XC40313010 FF+10d, XC40312015 FS-10d | 100% |  | 2011-07-04 | 2011-08-31 |  |  |  |  | Precast Concrete Works [235 cbm]; Precast concrete works [588 h] | 23,500 | 13,500 | 588,00 | 27.8. | XC40313015 | 588 | 0 |  | 934 | 31 | 200 | 200 | C | MO04 | X | C | XC40 | 3130 | C | 31 | X | OB | LND | 3130 | MO11 |  |  |  |  | C7 | CA16 - critical - CW05 | UDF_G4 |  |  |  |  |  |  |  |  |  |  |  |  |
| XC40313022 |  | CA31 Service Area - Erection Precast Elements finished | milestone | 0d | 2011-07-30 A | 2011-07-30 A | XC40313015 FF | 100% |  |  |  |  |  |  | TB26 - V - Construct-Winter partly * |  |  |  |  |  | XC40313022 | 0 | 0 |  | 934 | 31 | 200 | 200 | C | MO04 | X | C | XC40 | 3130 | C | 31 | X | OB | LND | 3120 | MO11 |  | P | 2011-08-30 | 2011-07-30 | D |  |  | MO-11 3101: 21.08.11 compl. | 2011-08-21 | 2011-08-21 |  |  |  |  |  |  |  |  |  |
| XC403130 |  | CA31 Service Area SK3103 - Concrete Works Celling |  | 31d | 2011-08-20 A | 2011-10-15 | XC200C10, XC40313015 FS-10d, EC48313003 (other project) FS+5d, EC48313005 (other project), EC45313005 (other project) SS+40d, XC153130, EC45313015 (other project) |  | 43d | 2011-08-20 | 2011-09-24 | -135d | 0d |  | TB26 - V - Construct-Winter partly * | Concrete works [1110 cbm]; Concrete works [33300 h] |  |  | 33300,00 | 27.8. | XC403130 | 33300 | 0 | x | 934 | 31 | 200 | 200 | C | MO03 | X | C | XC20 | 3130 | C | 31 | X | mai | LND | 3130 | MO11 |  |  |  |  | D |  | UDF_G4 | until mid oct |  |  |  |  |  |  |  |  |  |  |  |
| XC303130 |  | CA31 Service Area SK3103- UG Installation (incl. Precast Manholes) |  | 40d | 2011-10-06 | 2011-11-30 | XC300C00, XC300C10, XC310C00, P3C02D4 (other project) FS+10d, P3R02BS (other project), EC303130 (other project) FS+10d, P3R02S1 (other project), P3R02BS (other project) FF+20d, P3R02AS1 (other project), ER443130 (other project), XC403130 SS+40d, XC300C00 SS |  |  |  |  | -135d | 15d |  | TB26 - V - Construct-Winter partly * |  |  |  |  |  | XC303130 | 0 | 0 |  | 934 | 31 | 200 | 200 | C | CiC | X | C | XC30 | 3130 | C | 31 | X | UG | LND | 3130 |  |  |  |  |  | C5 |  |  |  |  |  | 1 |  |  |  |  |  |  |  |  |
| XC40313020 |  | CA31 Service Area SK3103 - Concrete Works Eqpt Fdtn |  | 7d | 2011-10-17 | 2011-10-24 | XC40313015, EC48313010 (other project), XC403130 |  |  |  |  | -91d | 35d |  | TB26 - V - Construct-Winter partly * | Concrete works [900 cbm]; Concrete works [27000 h] | 1,080,000 |  | 27000,00 |  | XC40313020 | 27000 | 0 |  | 934 | 31 | 200 | 200 | C | MO04 | X | C | XC40 | 3130 | C | 31 | X | OB | LND | 3110 | MO11 |  |  |  |  | D |  | UDF_G4 |  |  |  |  |  |  |  |  |  |  |  |  |
| XC193130 |  | CA31 Service Area SK3103 - Backfill |  | 25d | 2011-10-24 | 2012-03-01 | XC303130 SS, XC303110 FF+15d, XC913130 FF+10d, XC303130 FF+10d |  |  |  |  | -125d | 0d |  | TB26 - T - Construct-Winter-3 (Dec/Jan/Feb free) * | Backfill & Compaction [4600 cbm]; Backfill & Compaction [6900 h] | 414,000 |  | 6900,00 |  | XC193130 | 6900 | 0 |  | 934 | 31 | 200 | 200 | C | MO04 | X | C | XC19 | 3130 | C | 31 | X | UG | LND | 3130 | MO11 |  |  |  |  |  |  |  |  |  |  |  | XC303110 |  |  |  |  |  |  |  |
| XC603130 |  | CA31 Service Area SK3103 - Paving inside |  | 60d | 2011-11-05 | 2012-01-20 | XC193130 SS+10d, EC603130 (other project) FS+20d |  |  |  |  | -125d | 0d |  |  | Concrete paved areas & concrete Roads [2100 sqm]; Concrete paved areas & concrete roads [7875 h] | 4,730.16 |  | 7875,00 |  | XC603130 | 7875 | 0 |  | 934 | 31 | 200 | 200 | C | MO04 | X | C | XC60 | 3130 | C | 31 | X | PV | LND | 3130 | MO11 |  |  |  |  |  |  |  |  |  |  | 1 | XC303140 |  |  |  |  |  |  |  |
| XC503130 |  | CA31 Service Area - Finishing Works Rooms |  | 70d | 2011-11-17 | 2012-02-13 | XC603130 SS+10d, XC510C00 FS+15d, XN803130 FS-45d, XC003130 FF-10d, EC503130 (other project) |  |  |  |  | -125d | 0d |  |  | Finishing Works - Warehouse CA31 [5000 mhr]; Finishing Works - Warehouse CA31 [5000 h] | 500,000 |  | 5000,00 |  | XC503130 | 5000 | 0 |  | 934 | 31 | 200 | 200 | C | CiC | X | C | XC50 | 3130 | C | 31 | X | OB | LND | 3130 |  |  |  |  |  |  |  |  |  |  |  | 1 |  | x | XC50 | 31 |  |  |  |  |
| XC503130_1 |  | CA31 Service Area - Plastering and Painting |  | 20d | 2011-11-17 | 2011-12-09 | XC503130 SS |  |  |  |  | -125d | 26d |  |  |  |  |  | 5000,00 |  | XC503130 | 5000 | 0 |  | 934 | 31 | 200 | 200 | C | CiC | X | C | XC50 | 3130 | C | 31 | X | OB | LND | 3130 |  |  |  |  |  |  |  |  |  |  |  | 1 |  | x |  | 31 |  |  |  |  |
| XC523130 |  | CA31 Service Area - Install False Floor |  | 40d | 2011-11-29 | 2012-01-20 | XC40313015 SS+20d, EC523130 (other project), XC40313022 FF+20d, XC503130 SS+10d |  |  |  |  | -76d | 34d |  |  |  |  |  |  |  | XC523130 | 0 | 0 |  | 934 | 31 | 200 | 200 | C | MO04 | X | C | XC52 | 3130 | C | 31 | X | OB | LND | 3130 |  |  |  |  |  | D |  |  |  |  |  |  |  |  |  |  |  |  |  |  |
| XC50313010 |  | CA31 Service Area - Finishing Works Rooms finished | milestone | 0d | 2012-02-13 | 2012-02-13 | XC503130 FF |  |  |  |  | -76d | 34d |  |  |  |  |  |  |  | XC50313010 | 0 | 0 |  | 934 | 31 | 200 | 200 | C | CiC | X | C | XC50 | 3130 | C | 31 | X | OB | LND | 3120 |  |  |  |  |  | D |  |  |  |  |  | 1 |  |  |  |  |  |  |  |  |
| XC50313005 |  | CA31 Service Area - Punch out & rectification |  | 30d | 2012-05-14 | 2012-06-18 | XC503130, XC510C00 FS+15d, XN603130 |  |  |  |  | 58d | 128.5d |  |  | Finishing Works - Warehouse CA31 [973 mhr]; Finishing Works - Warehouse CA31 [973 h] | 97,300 |  | 973,00 |  | XC50313005 | 973 | 0 |  | 934 | 31 | 200 | 200 | C | CiC | X | C | XC50 | 3130 | C | 16 | X | SS | LND | 1610 |  |  |  |  |  |  |  |  |  |  |  | 1 |  |  |  |  |  |  |  |  |
|  | N | **Structural Steel** |  |  | 2011-03-01 | 2012-05-12 |  |  |  |  |  |  |  |  |  |  |  |  |  |  |  |  |  |  |  |  |  |  |  |  |  |  |  |  |  |  |  |  |  |  |  |  |  |  |  |  |  |  |  |  |  |  |  |  |  |  |  |  |  |  |
| XN703103 |  | CA31 Service Area SK3103_01 - KMD Assy Drawings | milestone | 0d | 2011-03-01 A | 2011-03-01 A |  | 100% |  |  |  |  |  | finish on 2011-03-01 |  |  |  |  | 22t |  | XN703103 | 0 | 0 |  | 934 | 31 | 200 | 200 | C | LND | X | N | XN05 | 3130 | N | 31 | X | SS | LND | 3130 |  |  |  |  |  | KMD |  |  |  |  |  |  |  |  |  |  | x | XNK |  |  |
| XN723103 |  | CA31 Service Area SK3103_02-03 - KMD Assy Drawings | milestone | 0d | 2011-03-01 A | 2011-03-01 A |  | 100% |  |  |  |  |  | finish on 2011-03-01 |  |  |  |  | 22t |  | XN723103 | 0 | 0 |  | 934 | 31 | 200 | 200 | C | LND | X | N | XN05 | 3130 | N | 31 | X | SS | LND | 3130 |  |  |  |  |  | KMD |  |  |  |  |  |  |  |  |  |  | x | XNK |  |  |
| XN743103 |  | CA31 Warehouse SK3103_40- KMD Assy Drawings (welded sections) | milestone | 0d | 2011-05-03 A | 2011-05-03 A |  | 100% |  |  |  |  |  | finish on 2011-04-25 |  |  |  |  | 22t |  | XN743103 | 0 | 0 |  | 934 | 31 | 200 | 200 | C | LND | X | N | XN05 | 3130 | N | 31 | X | SS | LND | 3130 |  |  |  |  |  | KMD |  |  |  |  |  |  |  |  |  |  | x | XNK |  |  |
| XN713103 |  | CA31 Service Area SK3103_01- Steel Deliveries | milestone | 0d | 2011-05-04 A | 2011-05-04 A |  | 100% |  |  |  |  |  | finish on 2011-05-04 | TB26 - 3 - Construction Normal 7days * CA17 |  |  |  | 22t |  | XN713103 | 0 | 0 |  | 934 | 31 | 200 | 200 | C | LND | X | N | XN06 | 3130 | N | 31 | X | SS | LND | 3130 |  |  |  |  |  | SD |  |  |  |  |  |  |  |  |  |  |  | XNK |  |  |
| XN733103 |  | CA31 Service Area SK3103_02-03- Steel Deliveries | milestone | 0d | 2011-05-04 A | 2011-05-04 A |  | 100% |  |  |  |  |  | finish on 2011-05-04 | TB26 - 3 - Construction Normal 7days * CA17 |  |  |  | 22t |  | XN733103 | 0 | 0 |  | 934 | 31 | 200 | 200 | C | LND | X | N | XN06 | 3130 | N | 31 | X | SS | LND | 3130 |  |  |  |  |  | SD |  |  |  |  |  |  |  |  |  |  |  | XNK |  |  |
| XN753103 |  | CA31 Warehouse SK3103_40 - Steel Deliveries (welded sections) | milestone | 0d | 2011-05-04 A | 2011-05-04 A |  | 100% |  |  |  |  |  | finish on 2011-05-04 | TB26 - 3 - Construction Normal 7days * CA17 |  |  |  | 22t |  | XN753103 | 0 | 0 |  | 934 | 31 | 200 | 200 | C | LND | X | N | XN06 | 3130 | N | 31 | X | SS | LND | 3130 |  |  |  |  |  | SD |  |  |  |  |  |  |  |  |  |  |  | XNK |  |  |
| XN203130 |  | CA31 Service Area SK3103 - Install Primary Steel (Roof) |  | 20d | 2011-09-26 | 2011-10-18 | XN703103, XN713103 FS+10d, XN723103, XN733103 FS+10d, XN753103 FS+10d, P3N02ДN (other project), XC40313015, XN743103 |  |  |  |  | -106d | 20d | start on or after 2011-09-26 | TB26 - V - Construct-Winter partly * | Piperacks, Main Structures; Piperacks, Main structures |  |  | 8075,00 |  | XN203130 | 8075 | 0 |  | 934 | 31 | 200 | 200 | C | LND | X | N | XN80 | 3130 | N | 31 | X | SS | LND | 3140 | OMUS-1 |  |  |  |  | D |  |  |  |  |  |  |  |  |  |  |  |  | Check Roof - Cladding |  |
| XN803130 |  | CA31 Service Area SK3103 - Install Cladding |  | 50d | 2011-10-31 | 2012-02-20 | P3N02ДN (other project) FF+30d, P3N03N (other project), XN203130 FS-10d, EN803130 (other project), XC40313020 FF+20d, XC40313015 SS+30d |  |  |  |  | -126d | 0d | start on or after 2011-10-31 | TB26 - V - Construct-Winter partly * | Cladding [2750 sqm]; Cladding [13750 h] |  |  | 13750,00 |  | XN803130 | 13750 | 0 |  | 934 | 31 | 200 | 200 | C | LND | X | N | XN80 | 3130 | N | 31 | X | SS | LND | 3130 | OMUS-1 |  |  |  |  | D |  |  |  |  |  |  |  |  |  |  |  | XNK |  |  |
| XN303130 |  | CA31 Service Area SK3103 - Install Platforms |  | 30d | 2012-02-21 | 2012-04-05 | EN803130 (other project), XN803130, P3N02ДN (other project), EN283100 (other project) FF |  |  |  |  | 58d | 0d |  | TB26 - V - Construct-Winter partly * | Ladders & platforms [2 t]; Ladders & platforms [200 h] | 88.69 |  | 200,00 |  | XN303130 | 200 | 0 |  | 934 | 31 | 200 | 200 | C | LND | X | N | XN30 | 3130 | N | 31 | X | SS | LND | 3130 | OMUS-1 |  |  |  |  |  |  |  |  |  |  |  |  |  |  |  |  | XNK | Check Roof - Cladding | t |
| XN403130 |  | CA31 Service Area SK3103 - Install Railings,Ladders,etc. |  | 40d | 2012-03-23 | 2012-05-12 | XN303130 SS+20d |  |  |  |  | 58d | 0d |  | TB26 - V - Construct-Winter partly * | Ladders & platforms [1 t]; Ladders & platforms [100 h] |  |  | 100,00 |  | XN403130 | 100 | 0 |  | 934 | 31 | 200 | 200 | C | LND | X | N | XN40 | 3130 | N | 31 | X | SS | LND | 3130 | OMUS-1 |  |  |  |  |  |  |  |  |  |  |  |  |  |  |  |  | XNK | Check Roof - Cladding |  |
| XN603130 |  | CA31 Service Area SK3103 - Install Gratings |  | 20d | 2012-04-18 | 2012-05-12 | XN403130 FF, PN693130 (other project) |  |  |  |  | 58d | 0d |  | TB26 - V - Construct-Winter partly * | Grating [30 sqm]; Grating [112.5 h] | 51.74 |  | 112,50 |  | XN603130 | 112,5 | 0 |  | 934 | 31 | 200 | 200 | C | LND | X | N | XN60 | 3130 | N | 31 | X | SS | LND | 3130 | OMUS-1 |  |  |  |  |  |  |  |  |  |  |  |  |  |  |  |  | XNK | Check Roof - Cladding |  |

Notes:
- XW503120: P3 Activity Log Info: Clarification Surface / Protection during Prefab / Current Status: 21.01.2010 - Volkmann - Piping surface Protection / predecessor piping reinstallment deleted. this is final touchup after / MC!
- XV303120: Current Status: 110315 (WL): Add PRED XM103120 CA31 CA31 Blower Sec - Install / Convey.Compressors / 110315 (WL): Delete PRED XE803120 CA31 CA31 Blower Sec - Install Heat / Tracing
- XC153130: P3 Activity Log Info: 600 driven piles expected, 20/d/machine
- XC303130: P3 Activity Log Info: Clarification Prefab / Catch Basins/pulling pits
- XN713103: Scope: 09.02.2011: weight: 25 ton
- XN733103: Scope: 09.02.2011: weight: 25 ton
- XN753103: Scope: 09.02.2011: weight: 65 ton
- XN803130: Current Status: 20110806 Delivery in October 2011 (Info from Fr. Schilka 02.08.2011)

| ID | WBS | Activity | Type | Duration | Start | Finish | Predecessors | Complete | Remaining | Total float | Free float | Calendar | Resources | Cost | Actual cost | Filter | TB26 Ressource Budget | UDF_SELECT | Comments | UDF_CONTRACT START DATE | UDF_CONTRACT FINISH DATE | UDF_L3 START DATE | UDF_L3 FINISH DATE | UDF_SAVE ACT ID | UDF_BUDGETED LABOR UNIT | UDF_ACTUAL LABOR UNIT | Department | Type of Work | Constr. Area | PMT-Area | PMT-Schedule Org | PMT-Phase | PMT-Respons. | WBS Phase | WBS Discipline | WBS Type of Work | WBS Objects | Russia WBS Discipline (Russia) | Russia Construction Area | Russia WBS Phase | IMS | UPT | Russia WBS Objects | Subcontractor | Check ResLoading | UDF_CONTRACT ITEM | UDF_CONTRACT DATE PENALIZED | UDF_SELECT UPDATE PROGRESS | UDF_CHECK RESOURCE DATES | UDF_PLANNED START | UDF_PLANNED FINISH | UDF_PENALIZED FINISH | UDF_CONTRACT FINISH DATE REV1 | UDF_CONTRACT START DATE REV1 | UDF_INDICATOR | Zeigen/n. Zeigen | TB26 Semantics | TB26 Material Res Values | UDF_ELECTRICAL START | UDF_ELECTRICAL FINISH | UDF_CHECK BASELINE | UDF_COMMENTS_0827 | geplanter Start | geplantes Ende |
| --- | --- | --- | --- | --- | --- | --- | --- | --- | --- | --- | --- | --- | --- | --- | --- | --- | --- | --- | --- | --- | --- | --- | --- | --- | --- | --- | --- | --- | --- | --- | --- | --- | --- | --- | --- | --- | --- | --- | --- | --- | --- | --- | --- | --- | --- | --- | --- | --- | --- | --- | --- | --- | --- | --- | --- | --- | --- | --- | --- | --- | --- | --- | --- | --- |
|  | H | **HVAC** |  |  | 2012-01-17 | 2012-06-02 |  |  |  |  |  |  |  |  |  |  |  |  |  |  |  |  |  |  |  |  |  |  |  |  |  |  |  |  |  |  |  |  |  |  |  |  |  |  |  |  |  |  |  |  |  |  |  |  |  |  |  |  |  |  |  |  |  |  |
| XH00313005 |  | CA31 Service Area - Installation HVAC |  | 60d | 2012-01-17 | 2012-03-28 | XN803130 SS+35d, P3H01SS (other project), XH000000 FF, EH30313005 (other project), XC503130_1 |  |  | -151d | 0d |  | HVAC - Warehouse CA31 [1827 mhr]; HVAC - Warehouse CA31 [1827 h] |  |  | x | 1827,00 | REL XC50 | Reduce OD 70>60d | 2011-05-10 | 2011-07-15 | 2011-07-19 | 2011-09-23 | XH00313005 | 1827 | 0 | 934 | XBB | 31 | 200 | 200 | C | LND | X | H | XH00 | 3100 | H | 31 | X | hvac | LND | 3130 | ARMO | 31 |  |  |  |  |  |  |  |  |  |  |  |  |  |  |  |  |  |  |  |
| XH00313010 |  | CA31 Service Area - Testing/Commissioning HVAC (Start w. temp. Power) |  | 70d | 2012-03-12 | 2012-06-02 | X0300080, XH00313005 FS-15d, X0300008 FS+20d, XH000C10 |  |  | 70d | 0d |  |  |  |  |  |  |  |  | 2011-07-10 | 2011-09-15 | 2011-09-06 | 2011-11-12 | XH00313010 | 0 | 0 | 934 | XBB | 31 | 200 | 200 | C | LND | X | H | XH20 | 3130 | H | 31 | X | hvac | LND | 3130 | ARMO |  |  |  |  |  |  |  |  |  |  |  |  |  |  |  |  |  |  |  |  |
| XH00313007 |  | CA31 Service Area - HVAC ready for Heating | milestone | 0d | 2012-03-23 | 2012-03-23 | XH00313010 SS+10d |  |  | 314.5d | 130.5d |  |  |  |  |  |  |  |  |  |  | 2011-09-17 | 2011-09-17 | XH00313007 | 0 | 0 | 934 | XBB | 31 | 200 | 200 | C | LND | X | H | XH00 | 3130 | H | 31 | X | hvac | LND | 3130 | ARMO |  | CM10 |  |  |  |  |  |  |  |  |  |  |  |  |  |  |  |  |  |  |
| XH00313006 |  | CA31 Service Area - Installation HVAC finished | milestone | 0d | 2012-03-28 | 2012-03-28 | XH00313005 FF |  |  | 125d | 195.5d |  |  |  |  |  |  |  |  | 2011-07-15 | 2011-07-15 | 2011-09-23 | 2011-09-23 | XH00313006 | 0 | 0 | 934 | XBB | 31 | 200 | 200 | C | LND | X | H | XH00 | 3130 | H | 31 | X | hvac | LND | 3130 | ARMO |  | CM10 | P |  |  |  |  |  |  |  |  |  |  |  |  |  |  |  |  |  |
| XH00313015 |  | CA31 Service Area - Testing/Commissioning HVAC finished | milestone | 0d | 2012-06-02 | 2012-06-02 | XH00313010 FF |  |  | 70d | 140.5d |  |  |  |  |  |  |  |  | 2011-09-15 | 2011-09-15 | 2011-11-12 | 2011-11-12 | XH00313015 | 0 | 0 | 934 | XBB | 31 | 200 | 200 | C | LND | X | H | XH20 | 3130 | H | 31 | X | hvac | LND | 3130 | ARMO |  | CM11 |  |  |  |  |  |  |  |  |  |  |  |  |  |  |  |  |  |  |
|  | U | **Package Units** |  |  |  |  |  |  |  |  |  |  |  |  |  |  |  |  |  |  |  |  |  |  |  |  |  |  |  |  |  |  |  |  |  |  |  |  |  |  |  |  |  |  |  |  |  |  |  |  |  |  |  |  |  |  |  |  |  |  |  |  |  |  |
|  | B | **Mechanical - Stationary Equipment** |  |  |  |  |  |  |  |  |  |  |  |  |  |  |  |  |  |  |  |  |  |  |  |  |  |  |  |  |  |  |  |  |  |  |  |  |  |  |  |  |  |  |  |  |  |  |  |  |  |  |  |  |  |  |  |  |  |  |  |  |  |  |
|  | M | **Mechanical - Rotating Equipment** |  |  |  |  |  |  |  |  |  |  |  |  |  |  |  |  |  |  |  |  |  |  |  |  |  |  |  |  |  |  |  |  |  |  |  |  |  |  |  |  |  |  |  |  |  |  |  |  |  |  |  |  |  |  |  |  |  |  |  |  |  |  |
|  | R | **Piping** |  |  | 2011-07-18 | 2012-05-31 |  |  |  |  |  |  |  |  |  |  |  |  |  |  |  |  |  |  |  |  |  |  |  |  |  |  |  |  |  |  |  |  |  |  |  |  |  |  |  |  |  |  |  |  |  |  |  |  |  |  |  |  |  |  |  |  |  |  |
| XR203130 |  | CA31 Service Area - Piping Prefabrication |  | 124d | 2011-07-18 A | 2011-12-09 | ER49313005 (other project) SS+18d, ER493130 (other project) SS+18d |  | 89d | -125d | 26d |  | A/G piping prefabrication [200 Fpi]; A/G Piping (Prefab) [750 h] | 2,697.67 |  |  | 750,00 |  |  |  |  |  |  | XR203130 | 750 | 0 | 934 |  | 31 | 200 | 200 | C | LND | X | R | XR20 | 3130 | R | 31 | X | PRP | LND | 3130 | OMUS-1 |  |  |  | 27.8. | actual finish |  |  |  |  |  |  |  |  |  |  |  |  |  |  |  |
| XR403130 |  | CA31 Service Area - Piping Installation |  | 88d | 2012-01-17 | 2012-04-30 | P3J04CS1 (other project), XR203130, IMS-C-000190 FF, XN803130 FF+10d, XH00313005 SS |  |  | -151d | 0d |  | A/G piping field installation [230 Fpi]; A/G Piping (Field) [1437.5 h]; Deluge Piping [1000 Fpi]; Deluge piping [6250 h] | 259,593.36 |  |  | 7687,50 |  |  | 2011-03-01 | 2012-01-30 |  |  | XR403130 | 7687,5 | 0 | 934 |  | 31 | 200 | 200 | C | LND | X | R | XR40 | 3130 | R | 31 | X | PI | LND | 3130 | OMUS-1 |  | E-06-03-08 |  |  |  | 2011-06-28 |  |  |  |  |  |  |  |  |  |  |  |  |  |  |
| XR603130 |  | CA31 Service Area - Piping Pressure Tests |  | 20d | 2012-05-02 | 2012-05-25 | X0300020, XR403130, XR600C00 SS |  |  | 256.5d | 0d | TB26 - T - Construct-Winter-3 (Dec/Jan/Feb free) * |  |  |  |  | 160 |  |  | 2011-03-01 | 2012-01-30 |  |  | XR603130 | 0 | 0 | 934 |  | 31 | 200 | 200 | C | LND | X | R | XR60 | 3130 | R | 31 | X | HY | LND | 3130 | OMUS-1 |  | E-06-03-08 |  |  |  |  |  |  |  |  |  |  |  |  |  |  |  |  |  |  |
| XR803130 |  | CA31 Service Area - Piping Reinstatement |  | 10d | 2012-05-21 | 2012-05-31 | XR603130 FF+5d, IMS-C-000360 FF |  |  | 256.5d |  |  |  |  |  |  | 80 |  |  | 2011-03-01 | 2012-01-30 |  |  | XR803130 | 0 | 0 | 934 |  | 31 | 200 | 200 | C | LND | X | R | XR80 | 3130 | R | 31 | X | PI | LND | 3130 | OMUS-1 |  | E-06-03-08 |  |  |  |  | 2011-05-28 |  |  |  |  |  |  |  |  |  |  |  |  |  |
|  | E | **Electrical** |  |  | 2010-06-04 | 2012-09-03 |  |  |  |  |  |  |  |  |  |  |  |  |  |  |  |  |  |  |  |  |  |  |  |  |  |  |  |  |  |  |  |  |  |  |  |  |  |  |  |  |  |  |  |  |  |  |  |  |  |  |  |  |  |  |  |  |  |  |
| XC913130 |  | CA31 Service Area - Install Earthing&Lightn.System_CIVIL |  | 74d | 2010-06-04 A | 2010-08-28 A | XC403130 SS+10d, EE903130 (other project), EE900010 (other project) | 100% |  |  |  |  | Grounding & Lightning [4837.5 h]; Grounding & Lightning [430 pcs] | 193,500 | 193,500 |  | 4837,50 |  |  | 2011-03-30 | 2011-10-10 |  |  | XC913130 | 4837,5 | 4837,5 | 934 |  | 31 | 200 | 200 | C | LND | X | C | XE91 | 3130 | C | 31 | X | EA | LND | 3130 | MO11 |  | E-16-07-13 |  |  |  |  |  |  |  |  |  |  |  |  |  |  |  |  |  |  |
| XE913130 |  | CA31 Service Area - Install Earthing&Lightn.System_E/I |  | 15d | 2011-12-10 | 2011-12-27 | XN203130, XC503130 SS+20d |  |  | 149d | 244d |  |  |  |  |  | 475 |  |  | 2011-03-30 | 2011-10-10 |  |  | XE913130 | 0 | 0 | 934 |  | 31 | 200 | 200 | C | LND | X | E | XE91 | 3130 | E | 31 | X | EA | LND | 3130 | URMA |  | E-16-07-13 |  |  |  |  |  | 2012-05-30 | 2012-05-30 | 2011-10-01 | UDF_G2 |  |  |  |  |  |  |  |  |  |
| XE203130 |  | CA31 Service Area - Install Trafo's, SG, MCC's |  | 80d | 2012-03-02 | 2012-06-06 | P3E02S2 (other project), EE203130 (other project), XC40313020, XE413130 FF+20d, P3E07S3 (other project), XN803130, XC503130 FS-20d, X3E105 FF, XC603130, P3E01BS2 (other project), XC40313015, XC50313010 FS-20d, XC523130 |  |  | -110d | 0d |  | Main Equipment Substations [80 pcs]; Installation main equipment substation [3000 h] | 120,000 |  |  | 3000,00 |  |  | 2011-03-30 | 2011-10-10 |  |  | XE203130 | 3000 | 0 | 934 |  | 31 | 200 | 200 | C | LND | X | E | XE20 | 3130 | E | 31 | X | EL | LND | 3130 | URMA |  | E-16-07-13 | x |  |  |  |  | 2012-05-30 | 2012-05-30 | 2011-10-01 | UDF_G2 | D |  |  |  |  |  |  |  |  |
| XE413130 |  | CA31 Service Area - Install Cable Trays |  | 50d | 2012-03-15 | 2012-05-14 | EE203130 (other project), EE46313010 (other project), EE46510120 (other project) FF, XC503130 SS+20d, XR403130 FS-40d |  |  | -151d | 0d |  | Cable trays/conduits [850 m]; Cable trays [2550 h] | 102,000 |  |  | 2550,00 |  |  | 2011-03-30 | 2011-05-20 |  |  | XE413130 | 2550 | 0 | 934 |  | 31 | 200 | 200 | C | LND | X | E | XE41 | 3130 | E | 31 | X | EL | LND | 3130 | URMA |  | E-15-01-12 |  |  |  |  |  |  | 2011-11-30 | 2011-10-01 | UDF_G2 |  | m | 900 | 2011-08-18 | 2011-10-26 | x | to be checked |  |  |
| XE703130 |  | CA31 Service Area - Install Lighting & Small Power |  | 60d | 2012-04-13 | 2012-06-25 | XP341610 FS+50d, XE413130 FS-25d, P3E03S2 (other project) FF+20d, XH00313005 SS+20d, EE763130 (other project), EE76510110 (other project), XN803130, XC503130 SS+20d |  |  | -20d | 0d |  | Cable Pulling [3000 m]; Lighting illuminates [230 pcs]; Lighting (iluminates) [2300 h]; Cable pulling [1500 h] | 152,000 |  | x | 3800,00 |  |  | 2011-05-10 | 2012-01-31 |  |  | XE703130 | 3800 | 0 | 934 |  | 31 | 200 | 200 | C | LND | X | E | XE70 | 3130 | E | 31 | X | EL | LND | 3130 | URMA |  | E-16-03-01 |  |  |  |  |  |  | 2012-05-10 | 2011-08-15 | UDF_G2 |  |  |  |  |  |  |  |  |  |
| XE503130 |  | CA31 Service Area - CablePulling Trafos/SGs intern |  | 60d | 2012-05-02 | 2012-07-12 | XE413130 FF+20d, P3E15CS (other project), P3E15AS (other project), XE203130 FF+30d, XE500C01, P3E15BS (other project), EE563130 (other project) |  |  | -70d | 0d | TB26 - V - Construct-Winter partly * | Cable Pulling [15000 m]; Cable pulling [7500 h] | 300,000 |  |  | 7500,00 |  |  | 2011-05-20 | 2012-02-10 |  |  | XE503130 | 7500 | 0 | 934 |  | 31 | 200 | 200 | C | LND | X | E | XE50 | 3130 | E | 31 | X | EL | LND | 3130 | URMA |  | E-16-01-01 |  |  |  |  |  |  | 2012-07-01 | 2011-10-01 | UDF_G2 |  | m | 15500 | 2011-12-14 | 2012-02-29 |  |  |  |  |
| XE50313020 |  | CA31 Service Area - Cable Termination & Testing / LV Syst. CA16/31 |  | 90d | 2012-05-02 | 2012-08-16 | XE203130 FS-30d, XE50410015 |  |  | -110d | 0d |  | Cable connecting [420 pcs]; Cable connecting [1050 h] | 42,000 |  |  | 1050,00 |  |  | 2011-03-30 | 2011-10-10 |  |  | XE50313020 | 1050 | 0 | 934 |  | 31 | 200 | 200 | C | LND | X | E | XE60 | 3130 | E | 16 | X | ET | LND | 1610 | URMA |  | E-16-07-13 |  |  |  |  |  | 2012-05-30 | 2012-05-30 | 2011-10-01 | UDF_G2 |  |  |  |  |  |  |  |  |  |
| XE923130 |  | CA31 Service Area - Install Fire Detection System |  | 60d | 2012-06-26 | 2012-09-03 | XE703130, XH00313005, XC503130, XJ413130 |  |  | 176.5d | 0d |  | Fire Detection System; Fire detection system |  |  | x | 0,00 |  |  |  |  |  |  | XE923130 | 0 | 0 | 934 |  | 31 | 200 | 200 | C | UIO | X | E | XE92 | 3130 | E | 31 | X | FGDS | LND | 3130 |  |  |  |  |  |  |  |  |  |  |  | UDF_G2 |  |  |  |  |  | x |  | 2012-02-14 | 2012-06-27 |
| XE963130 |  | CA31 Service Area - Install Communication System |  | 60d | 2012-06-26 | 2012-09-03 | XH00313005, XJ413130, XE703130, E3E1350 (other project), XC503130, XE923130 SS |  |  | 176.5d |  |  | Communication System |  |  | x | 0,00 |  |  |  |  |  |  | XE963130 | 0 | 0 | 934 |  | 31 | 200 | 200 | C | LND | X | E | XE96 | 3130 | E | 31 | X | CS | LND | 3130 |  |  |  |  |  |  |  |  |  |  |  | UDF_G2 |  |  |  |  |  | x |  | 2012-02-14 | 2012-06-27 |
| XE50313010 |  | CA31 Service Area - Install. temp. LV-power generation CA31/16 |  | 25d | 2012-07-27 | 2012-08-25 | XE50161010 SS, XE413130 |  |  | 184d | 0d |  |  |  |  |  |  |  |  | 2011-05-20 | 2012-02-10 |  |  | XE50313010 | 0 | 0 | 934 |  | 31 | 200 | 200 | C | LND | X | E | XE50 | 3130 | E | 16 | X | EL | LND | 1610 | URMA |  | E-16-01-01 |  |  |  |  |  |  | 2012-07-01 | 2011-10-01 | UDF_G2 |  |  |  | 2011-10-01 | 2011-10-29 |  |  |  |  |
| XE50313015 |  | CA31 Service Area - LV power available only for test runs | milestone | 0d | 2012-08-25 | 2012-08-25 | XE50313010, XE503130 |  |  | 184d | 0d |  |  |  |  |  |  |  |  | 2011-05-20 | 2012-02-10 |  |  | XE50313015 | 0 | 0 | 934 |  | 31 | 200 | 200 | C | LND | X | E | XE50 | 3130 | E | 16 | X | EL | LND | 1610 | URMA |  | E-16-01-01 |  |  |  |  |  |  | 2012-07-01 | 2011-10-01 | UDF_G2 |  |  |  | 2011-10-29 | 2011-10-29 |  |  |  |  |

Notes:
- XH00313010: Current Status: 21.01.2011 - Siegel - Vorgдnger zur IBN HVAC / Condensat, LP-Dampf, Kьhlwasser von FF + 30 Tage Lag auf FS + 0 geдndert!
- XR403130: P3 Activity Log Info: Start with Fire Water System
- XE913130: UDF_PREDECESSOR: XN30, DEL XE40, DEL XE80, DEL XJ40, Civil 100%, Equipment 100%
- XE413130: UDF_PREDECESSOR: XN30, Piping 50%
- XE703130: UDF_PREDECESSOR: XE40, Civil 100%, HVAC ducts, Finishing works partly
- XE503130: UDF_PREDECESSOR: XE40, XE50, DEL XE34
- XE50313020: UDF_PREDECESSOR: XE50, Equipment 100%
- XE923130: Scope: CA31: / FDS - 146external sensors / Structured Cable System (SCS) / FOCL / DS + SAME / MDCN
- XE963130: Scope: CA31: / FDS - 146external sensors / Structured Cable System (SCS) / FOCL / DS + SAME / MDCN
- XE50313010: UDF_PREDECESSOR: XE40, XE50, DEL XE34
- XE50313015: UDF_PREDECESSOR: XE40, XE50, DEL XE34

| ID | WBS | Activity | Type | Duration | Start | Finish | Predecessors | Complete | Remaining | Planned start | Planned finish | Total float | Free float | Constraint | Calendar | Resources | Cost | Actual cost | Filter | TB26 Ressource Budget | UDF_SELECT | UDF_CONTRACT START DATE | UDF_CONTRACT FINISH DATE | UDF_CONTRACT ITEM | TB26 Semantics | TB26 Material Res Values | UDF_ELECTRICAL START | UDF_ELECTRICAL FINISH | UDF_CONTRACT FINISH DATE REV1 | UDF_CONTRACT START DATE REV1 | UDF_SAVE ACT ID | UDF_CHECK BASELINE | UDF_BUDGETED LABOR UNIT | UDF_ACTUAL LABOR UNIT | UDF_COMMENTS_0827 | UDF_PREDECESSOR | UDF_INDICATOR | Department | Constr. Area | PMT-Area | PMT-Schedule Org | PMT-Phase | PMT-Respons. | WBS Phase | WBS Discipline | WBS Type of Work | WBS Objects | Russia WBS Discipline (Russia) | Russia Construction Area | Russia WBS Phase | IMS | UPT | Russia WBS Objects | Subcontractor | Zeigen/n. Zeigen | UDF_CONTRACT INDICATOR | UDF_SELECT UPDATE PROGRESS | Comments | UDF_CONTRACT DATE PENALIZED | UDF_EXPECTED START | UDF_EXPECTED FINISH | UDF_PENALIZED START | UDF_PENALIZED FINISH | UDF_Concrete | UDF_CHECK CRITICAL PATH | UDF_BASELINE DEVELOPMENT | UDF_CHECK RESOURCE DATES | Check ResLoading |
| --- | --- | --- | --- | --- | --- | --- | --- | --- | --- | --- | --- | --- | --- | --- | --- | --- | --- | --- | --- | --- | --- | --- | --- | --- | --- | --- | --- | --- | --- | --- | --- | --- | --- | --- | --- | --- | --- | --- | --- | --- | --- | --- | --- | --- | --- | --- | --- | --- | --- | --- | --- | --- | --- | --- | --- | --- | --- | --- | --- | --- | --- | --- | --- | --- | --- | --- | --- | --- |
|  | J | **Instrumentation** |  |  | 2012-04-13 | 2012-10-19 |  |  |  |  |  |  |  |  |  |  |  |  |  |  |  |  |  |  |  |  |  |  |  |  |  |  |  |  |  |  |  |  |  |  |  |  |  |  |  |  |  |  |  |  |  |  |  |  |  |  |  |  |  |  |  |  |  |  |  |  |  |  |
| XJ413130 |  | CA31 Service Area - Install Instrumentation Cable Trays |  | 40d | 2012-04-13 | 2012-05-31 | XC523130 FS-20d, XE413130 FS-25d |  |  |  |  | -151d | 0d |  |  | Secondary cable trays [300 m]; Install secondary cable trays [1125 h] | 45,000 |  | x | 1125,00 | REL XC50 | 2011-03-30 | 2011-05-20 | E-15-01-12 | m | 450 | 2011-08-24 | 2011-09-27 | 2011-11-30 | 2011-10-01 | XJ413130 | x | 1125 | 0 | Equipment 100% | Equipment 100% | UDF_G2 | 934 | 31 | 200 | 200 | C | LND | X | J | XJ41 | 3130 | J | 31 | X | IN | LND | 3130 | URMA |  |  |  |  |  |  |  |  |  |  |  |  |  |  |
| XJ203130 |  | CA31 Service Area - Install System/ IC/ PD cabs |  | 40d | 2012-05-08 | 2012-06-25 | XH00313005 FF+20d, XC523130, P3U10S3 (other project), XJ413130 FS-20d, P3J06AS (other project), XJ200C00 SS, P3J05S (other project), P3J06CS2 (other project), P3J06S3 (other project), XC913130 |  |  |  |  | -151d | 0d |  |  | Main Equipment Control Building/RIB [3350 mhr]; Junction Boxes/Cabinets/Panels [38 pcs]; Installation Main Equipment Control Building/RIB [3350 h]; Install Junction Boxes/ Cabinets/ Panels [950 h] | 373,000 |  |  | 4300,00 |  | 2011-03-30 | 2011-11-30 | E-17-04-13 |  |  |  |  | 2012-06-30 | 2011-10-15 | XJ203130 |  | 4300 | 0 |  |  | UDF_G2 | 934 | 31 | 200 | 200 | C | LND | X | J | XJ20 | 3130 | J | 31 | X | IN | LND | 3130 | URMA |  |  |  |  |  |  |  |  |  |  |  |  |  |  |
| XJ393130 |  | CA31 Service Area - Install Earthing Eqpt |  | 40d | 2012-05-21 | 2012-07-06 | XJ203130 FF+10d |  |  |  |  | -100d | 20d |  |  |  |  |  |  |  |  | 2011-03-30 | 2011-11-30 | E-17-04-13 |  |  |  |  | 2012-06-30 | 2011-10-15 | XJ393130 |  | 0 | 0 |  | XJ30, XJ42, XJ44, DEL XJ32, DEL XR40 | UDF_G2 | 934 | 31 | 200 | 200 | C | LND | X | J | XJ39 | 3130 | J | 31 | X | IN | LND | 3130 | URMA |  |  |  |  |  |  |  |  |  |  |  |  |  |  |
| XJ513130 |  | CA31 Service Area - Pulling InstrCables internal |  | 60d | 2012-06-01 | 2012-08-10 | P3J17S1 (other project) FF, XJ203130 FS-20d, XE500C01 |  |  |  |  | -120d | 0d |  |  | Multicore cables [3400 m]; Pull multicore cables [1700 h] | 68,000 |  |  | 1700,00 |  | 2011-03-30 | 2011-11-30 | E-17-04-13 |  | 2450 | 2011-11-26 | 2012-02-10 | 2012-06-30 | 2011-10-15 | XJ513130 |  | 1700 | 0 |  |  | UDF_G2 | 934 | 31 | 200 | 200 | C | LND | X | J | XJ51 | 3130 | J | 31 | X | IN | LND | 3130 | URMA |  |  |  |  |  |  |  |  |  |  |  |  |  |  |
| XJ523130 |  | CA31 Service Area - Pulling Instrument Cables |  | 60d | 2012-06-22 | 2012-08-31 | XE413130 FS-25d, XE500C01, XJ525601 FS-15d, XE503130 FS-30d |  |  |  |  | -82.5d | 0d |  | TB26 - V - Construct-Winter partly * | Singlecore cables [5200 m]; Pull singlecore cables [3900 h] | 156,000 |  |  | 3900,00 |  | 2011-03-30 | 2011-11-30 | E-17-04-13 | m | 4991 | 2011-12-14 | 2012-02-29 | 2012-06-30 | 2011-10-15 | XJ523130 |  | 3900 | 0 |  | XE40, XJ32, XJ52 | UDF_G2 | 934 | 31 | 200 | 200 | C | LND | X | J | XJ52 | 3130 | J | 31 | X | IN | LND | 3130 | URMA |  |  |  |  |  |  |  |  |  |  |  |  |  |  |
| XJ2031305 |  | CA31 Service Area - SAT System/ IC/ PD cabs |  | 7d | 2012-06-26 | 2012-07-03 | XJ203130 |  |  |  |  | -27d | 0d |  |  |  |  |  |  | 4300,00 |  | 2011-03-30 | 2011-11-30 | E-17-04-13 |  |  |  |  | 2012-06-30 | 2011-10-15 | XJ203130 |  | 4300 | 0 |  |  | UDF_G2 | 934 | 31 | 200 | 200 | C | LND | X | J | XJ20 | 3130 | J | 31 | X | IN | LND | 3130 | URMA |  |  |  |  |  |  |  |  |  |  |  |  |  |  |
| XJ613130 |  | CA31 Service Area - Termin InstrCables internal |  | 90d | 2012-07-07 | 2012-10-19 | XJ513130 FS-30d, XJ203130 FS-20d, XJ393130 FS-20d, XE50313020 FS-45d |  |  |  |  | -120d | 0d |  |  | Termination Field [2822 mhr]; Termination field [2822 h] | 282,200 |  |  | 2822,00 |  | 2011-03-30 | 2011-11-30 | E-17-04-13 |  |  |  |  | 2012-06-30 | 2011-10-15 | XJ613130 |  | 2822 | 0 |  |  | UDF_G1 | 934 | 31 | 200 | 200 | C | LND | X | J | XJ61 | 3130 | J | 31 | X | IN | LND | 3130 | URMA |  |  |  |  |  |  |  |  |  |  |  |  |  |  |
|  | S | **Safety & Environment** |  |  |  |  |  |  |  |  |  |  |  |  |  |  |  |  |  |  |  |  |  |  |  |  |  |  |  |  |  |  |  |  |  |  |  |  |  |  |  |  |  |  |  |  |  |  |  |  |  |  |  |  |  |  |  |  |  |  |  |  |  |  |  |  |  |  |
|  | W | **Painting** |  |  | 2012-02-21 | 2012-04-09 |  |  |  |  |  |  |  |  |  |  |  |  |  |  |  |  |  |  |  |  |  |  |  |  |  |  |  |  |  |  |  |  |  |  |  |  |  |  |  |  |  |  |  |  |  |  |  |  |  |  |  |  |  |  |  |  |  |  |  |  |  |  |
| XW503130 |  | CA31 Service Area - Surf.Protection Piping |  | 40d | 2012-02-21 | 2012-04-09 | XN803130 |  |  |  |  | 115d | 185.5d |  |  | Piping painting [201 sqm]; Piping painting [503 h] | 198.08 |  |  | 503,00 |  |  |  |  |  |  |  |  |  |  | XW503130 |  | 503 | 0 |  |  |  | 934 | 31 | 200 | 200 | C | LND | X | W | XW50 | 3130 | W | 31 | X | PA | LND | 3130 | OMUS-1 |  |  |  |  |  |  |  |  |  |  |  |  |  |  |
|  | V | **Insulation** |  |  |  |  |  |  |  |  |  |  |  |  |  |  |  |  |  |  |  |  |  |  |  |  |  |  |  |  |  |  |  |  |  |  |  |  |  |  |  |  |  |  |  |  |  |  |  |  |  |  |  |  |  |  |  |  |  |  |  |  |  |  |  |  |  |  |
|  | 40 | **CA31 (3102)- Warehouse** |  |  | 2009-11-07 | 2012-10-29 |  |  |  |  |  |  |  |  |  |  |  |  |  |  |  |  |  |  |  |  |  |  |  |  |  |  |  |  |  |  |  |  |  |  |  |  |  |  |  |  |  |  |  |  |  |  |  |  |  |  |  |  |  |  |  |  |  |  |  |  |  |  |
|  | C | **Civil Work** |  |  | 2009-11-07 | 2012-05-22 |  |  |  |  |  |  |  |  |  |  |  |  |  |  |  |  |  |  |  |  |  |  |  |  |  |  |  |  |  |  |  |  |  |  |  |  |  |  |  |  |  |  |  |  |  |  |  |  |  |  |  |  |  |  |  |  |  |  |  |  |  |  |
| XC153140 |  | CA31 Warehouse - Piling outside SiloStructure |  | 71d | 2009-11-07 A | 2010-01-28 A | XC150C0020 SS, XC11310005 FF, F2910, P3C01D (other project), EC153140 (other project) FS+10d, XC113100 | 100% |  |  |  |  |  |  |  | Piles driven [2070 pcs]; Piles driven [15525 h] | 621,000 | 621,000 |  | 15525,00 |  |  |  |  |  |  |  |  |  |  | XC153140 |  | 15525 | 15525 |  |  |  | 934 | 31 | 200 | 200 | C | MO01 | X | C | XC15 | 3140 | C | 31 | X | P | LND | 3140 | MO11 |  |  |  |  |  |  |  |  |  |  |  |  |  |  |
| XC203140 |  | CA31 Warehouse - Concrete Works Bldg / Fdt |  | 315d | 2010-06-21 A | 2011-06-20 A | EC48314005 (other project) FF+20d, XC20311005 SS+30d, EC45314005 (other project) SS+10d, XC153140, IMS-C-000050 FF, EC45314015 (other project), EC48314003 (other project) | 100% |  | 2010-06-21 | 2011-08-31 |  |  |  | TB26 - V - Construct-Winter partly * | Concrete works [2720 cbm]; Concrete works [81600 h] | 58,942.27 |  |  | 81600,00 |  |  |  |  |  |  |  |  |  |  | XC203140 |  | 81600 | 81600 |  |  |  | 934 | 31 | 200 | 200 | C | MO03 | X | C | XC20 | 3140 | C | 31 | X | mai | LND | 3140 | MO11 | D |  |  |  |  |  |  |  |  |  |  |  |  |  |
| XC40314010 |  | CA31 Warehouse SK3102 - Precast Concrete Elements |  | 34d | 2011-07-11 A | 2011-08-18 A | P3C02D3 (other project) FF, XCC02D2, XC203140 FS-115d, EC48314006 (other project), EC48314004 (other project) | 100% |  |  |  |  |  | start on or after 2011-07-11 |  |  |  |  |  |  |  |  |  |  |  |  |  |  |  |  | XC40314010 |  | 0 | 0 |  |  |  | 934 | 31 | 200 | 200 | C | MO04 | X | C | XC40 | 3140 | C | 31 | X | pre | LND | 3140 | MO11 | D | UDF_G4 | 27.8. |  |  |  |  |  |  |  |  |  |  |  |
| XC40314015 |  | CA31 Warehouse SK3102 - Erection Precast Elements |  | 30d | 2011-07-25 A | 2011-08-18 A | XC203140 SS, XC40312015 SS, XC40314010 SS+25d | 100% |  | 2011-08-09 | 2011-09-12 |  |  |  | TB26 - V - Construct-Winter partly * | Precast Concrete Works [215 cbm]; Precast concrete works [537 h] | 21,500 | 2,000 |  | 537,00 |  |  |  |  |  |  |  |  |  |  | XC40314015 |  | 537 | 0 |  |  |  | 934 | 31 | 200 | 200 | C | MO04 | X | C | XC40 | 3140 | C | 31 | X | OB | LND | 3140 | MO11 | D |  | 27.8. |  |  |  |  |  |  |  |  |  |  |  |
| XC40314020 |  | CA31 Warehouse SK3102 - Erection Precast Elements finished | milestone | 0d | 2011-07-30 A | 2011-07-30 A | XC40314015 FF | 100% |  |  |  |  |  |  | TB26 - V - Construct-Winter partly * |  |  |  |  |  |  |  |  |  |  |  |  |  |  |  | XC40314020 |  | 0 | 0 |  |  |  | 934 | 31 | 200 | 200 | C | MO04 | X | C | XC40 | 3140 | C | 31 | X | OB | LND | 3120 | MO11 | D |  |  | MO-11: 27.07.11 compl. | P | 2011-07-27 | 2011-07-27 | 2011-06-30 | 2011-06-30 |  |  |  |  |  |
| XC303140 |  | CA31 Warehouse SK3102 - UG Installation inside |  | 30d | 2011-08-27 A | 2011-09-30 | XC310C00, P3C02D4 (other project) FS+10d, ER443140 (other project) FS-5d, XC300C00, P3R02S1 (other project), P3R02AS1 (other project), EC303140 (other project) FS+10d, XC203140, P3R02BS (other project) |  | 30d | 2011-08-25 | 2011-09-28 | -16d | 28d |  | TB26 - V - Construct-Winter partly * | Concrete Manholes; Fire water hydrants/monitors [3.5 pcs]; concrete manholes; fire water hydrants/ monitors [218.75 h] | 8,750 | 583.33 |  | 437,50 |  |  |  |  |  |  |  |  |  |  | XC303140 |  | 218,75 | 0 |  |  |  | 934 | 31 | 200 | 200 | C | CiC | X | C | XC30 | 3140 | C | 31 | X | UG | LND | 3140 |  | C5 |  | 27.8. |  |  |  |  |  |  | 1 | XC303140 | XC303140 | ok | UG |
| XC193140 |  | CA31 Warehouse SK3102 - Backfill |  | 58d | 2011-09-08 | 2011-11-21 | XC913140 FF+10d, XC303110 FF+15d, XC303140 SS+10d, XC303140 FF+10d |  |  |  |  | -16d | 0d |  | TB26 - T - Construct-Winter-3 (Dec/Jan/Feb free) * | Backfill & Compaction [19000 cbm]; Backfill & Compaction [28500 h] | 1,710,000 |  |  | 57000,00 |  |  |  |  |  |  |  |  |  |  | XC193140 |  | 28500 | 0 |  |  |  | 934 | 31 | 200 | 200 | C | MO04 | X | C | XC19 | 3140 | C | 31 | X | UG | LND | 3140 | MO11 |  | UDF_G4 |  |  |  |  |  |  |  |  |  |  |  | X |
| XC603140 |  | CA31 Warehouse SK3102 - Paving inside |  | 36d | 2011-09-20 | 2011-10-31 | XC193140 SS+10d, EC603140 (other project) FS+20d |  |  |  |  | -16d | 49d |  |  | Concrete paved areas & concrete Roads [6700 sqm]; Concrete paved areas & concrete roads [25125 h] | 22,065.47 |  |  | 25125,00 |  |  |  |  |  |  |  |  |  |  | XC603140 |  | 25125 | 0 |  |  |  | 934 | 31 | 200 | 200 | C | MO04 | X | C | XC60 | 3140 | C | 31 | X | PV | LND | 3140 | MO11 |  |  |  | ????? |  |  |  |  |  | 1 |  | XC303140 |  |  |
| XC503140 |  | CA31 Warehouse - Finishing Works (incl. Sanitary) |  | 140d | 2011-11-30 | 2012-05-22 | XC510C00 FS+15d, EC503140 (other project), XC003100 FF+60d, XC603140 FS-30d, XN803140 SS+15d |  |  |  |  | 50d | 0d |  |  | Finishing Works - Warehouse CA31 [23888 mhr]; Finishing Works - Warehouse CA31 [23888 h] | 2,388,800 |  | x | 23888,00 | XC50 |  |  |  |  |  |  |  |  |  | XC503140 |  | 23888 | 0 |  |  |  | 934 | 31 | 200 | 200 | C | CiC | X | C | XC50 | 3140 | C | 31 | X | OB | LND | 3140 |  |  |  |  |  |  |  |  |  |  | 1 |  |  |  | 31 |
| XC503140_1 |  | CA31 Warehouse - Plastering and Painting |  | 20d | 2011-11-30 | 2011-12-22 | XC503140 SS |  |  |  |  | 50d | 0d |  |  |  |  |  | x | 23888,00 |  |  |  |  |  |  |  |  |  |  | XC503140 |  | 23888 | 0 |  |  |  | 934 | 31 | 200 | 200 | C | CiC | X | C | XC50 | 3140 | C | 31 | X | OB | LND | 3140 |  |  |  |  |  |  |  |  |  |  | 1 |  |  |  | 31 |
| XC303145 |  | CA31 Warehouse SK3102 - UG Installation (incl. Precast Manholes) |  | 30d | 2012-03-02 | 2012-04-12 |  |  |  |  |  | 287.5d | 0d | start on or after 2012-03-02 | TB26 - V - Construct-Winter partly * | Concrete Manholes; Fire water hydrants/monitors [3.5 pcs]; concrete manholes; fire water hydrants/ monitors [218.75 h] | 8,750 |  |  | 437,50 |  |  |  |  |  |  |  |  |  |  | XC303140 |  | 218,75 | 0 |  |  |  | 934 | 31 | 200 | 200 | C | CiC | X | C | XC30 | 3140 | C | 31 | X | UG | LND | 3140 |  | C5 |  |  |  |  |  |  |  |  | 1 | XC303140 | XC303140 |  | UG |
| XC193145 |  | CA31 Warehouse SK3102 - Backfill |  | 30d | 2012-03-19 | 2012-04-24 | XC303145 SS+10d, XC303145 FF+10d |  |  |  |  | 286.5d |  |  | TB26 - T - Construct-Winter-3 (Dec/Jan/Feb free) * | Backfill & Compaction [19000 cbm]; Backfill & Compaction [28500 h] | 1,710,000 |  |  | 57000,00 |  |  |  |  |  |  |  |  |  |  | XC193140 |  | 28500 | 0 |  |  |  | 934 | 31 | 200 | 200 | C | MO04 | X | C | XC19 | 3140 | C | 31 | X | UG | LND | 3140 | MO11 |  |  |  |  |  |  |  |  |  |  |  | XC303140 |  | X |

Notes:
- XW503130: P3 Activity Log Info: Clarification Surface Protection during Prefab
- XC153140: P3 Activity Log Info: 1525 driven piles expected, 20/d/machine
- XC40314015: Current Status: 20110530 (O.Siegel): Nach Angaben von Goran R. werden die Arbeiten von MO11 / erst nach dem Backfill anfangen kцnnen. Aus heutiger Sicht nicht frьher als / Mitte August 2011
- XC303140: P3 Activity Log Info: Clarification Prefab Catch Basins/pulling / pits
- XC303145: P3 Activity Log Info: Clarification Prefab Catch Basins/pulling pits

| ID | WBS | Activity | Type | Duration | Start | Finish | Predecessors | Complete | Remaining | Planned start | Planned finish | Total float | Free float | Constraint | Calendar | Resources | Cost | TB26 Ressource Budget | UDF_SAVE ACT ID | UDF_CHECK BASELINE | UDF_BUDGETED LABOR UNIT | UDF_ACTUAL LABOR UNIT | Department | Type of Work | Constr. Area | PMT-Area | PMT-Schedule Org | PMT-Phase | PMT-Respons. | Zeigen/n. Zeigen | WBS Phase | WBS Discipline | WBS Type of Work | WBS Objects | Russia WBS Discipline (Russia) | Russia Construction Area | Russia WBS Phase | IMS | UPT | Russia WBS Objects | UDF_CONTRACT INDICATOR | UDF_CHECK CRITICAL PATH | Subcontractor | UDF_SELECT UPDATE PROGRESS | UDF_CHECK RESOURCE DATES | Comments | TB26 Semantics | Filter | UDF_SELECT | UDF_CONTRACT START DATE | UDF_CONTRACT FINISH DATE | UDF_CONTRACT DATE PENALIZED | UDF_L3 START DATE | UDF_L3 FINISH DATE | Check ResLoading |
| --- | --- | --- | --- | --- | --- | --- | --- | --- | --- | --- | --- | --- | --- | --- | --- | --- | --- | --- | --- | --- | --- | --- | --- | --- | --- | --- | --- | --- | --- | --- | --- | --- | --- | --- | --- | --- | --- | --- | --- | --- | --- | --- | --- | --- | --- | --- | --- | --- | --- | --- | --- | --- | --- | --- | --- |
|  | N | **Structural Steel** |  |  | 2011-05-03 | 2012-05-11 |  |  |  |  |  |  |  |  |  |  |  |  |  |  |  |  |  |  |  |  |  |  |  |  |  |  |  |  |  |  |  |  |  |  |  |  |  |  |  |  |  |  |  |  |  |  |  |  |  |
| XN703102 |  | CA31 Warehouse SK3102_01 - KMD Assy Drawings | milestone | 0d | 2011-05-03 A | 2011-05-03 A |  | 100% |  |  |  |  |  | finish on 2011-04-26 |  |  |  | 22t | XN703102 | x | 0 | 0 | 934 | XNK | 31 | 200 | 200 | C | LND | KMD | X | N | XN05 | 3140 | N | 31 | X | SS | LND | 3140 |  |  |  |  |  |  |  |  |  |  |  |  |  |  |  |
| XN723102 |  | CA31 Warehouse SK3102_02-06 - KMD Assy Drawings | milestone | 0d | 2011-05-03 A | 2011-05-03 A |  | 100% |  |  |  |  |  | finish on 2011-04-26 |  |  |  | 22t | XN723102 | x | 0 | 0 | 934 | XNK | 31 | 200 | 200 | C | LND | KMD | X | N | XN05 | 3140 | N | 31 | X | SS | LND | 3140 |  |  |  |  |  |  |  |  |  |  |  |  |  |  |  |
| XN743102 |  | CA31 Warehouse SK3102_40- KMD Assy Drawings (welded sections) | milestone | 0d | 2011-05-03 A | 2011-05-03 A |  | 100% |  |  |  |  |  | finish on 2011-04-25 |  |  |  | 22t | XN743102 | x | 0 | 0 | 934 | XNK | 31 | 200 | 200 | C | LND | KMD | X | N | XN05 | 3140 | N | 31 | X | SS | LND | 3140 |  |  |  |  |  |  |  |  |  |  |  |  |  |  |  |
| XN605503 |  | CA55 SR5503 - Install Gratings |  | 78d | 2011-05-16 A | 2011-07-08 A | XE405503, XN405503 SS, XN205503 | 100% |  | 2011-05-16 | 2011-08-15 |  |  |  |  | Grating [75 sqm]; Grating [281.25 h] | 1,241.67 | 281,75 | XN605503 | x | 281,25 | 105 | 934 | XNK | 55 | 200 | 200 | C | LND |  | X | N | XN60 | 5503 | N | 55 | X | SS | LND | 5503 | UDF_G4 | Check Roof - Cladding | ChSK |  |  |  |  |  |  |  |  |  |  |  |  |
| XN605502 |  | CA55 SR5502 - Install Gratings |  | 118d | 2011-06-01 A | 2011-11-26 | XN205502, XN405502 SS |  | 44d | 2011-06-01 | 2011-10-17 | 175d | 197.5d |  |  | Grating [60 sqm]; Grating [225 h] | 1,241.67 | 225,00 | XN605502 | x | 225 | 105 | 934 | XNK | 55 | 200 | 200 | C | LND |  | X | N | XN60 | 5502 | N | 55 | X | SS | LND | 5502 | UDF_G4 | Check Roof - Cladding | ChSK | 27.8. | x |  |  |  |  |  |  |  |  |  |  |
| XN605104 |  | CA51 SR5104 - Install Gratings |  | 26d | 2011-06-06 A | 2011-07-30 A | XN205104l, XN205104u | 100% |  | 2011-06-06 | 2011-07-06 |  |  |  |  | Grating [150 sqm]; Grating [562.5 h] | 1,241.67 | 562,50 | XN605104 | x | 562,5 | 450 | 934 | XNK | 51 | 200 | 200 | C | LND |  | X | N | XN60 | 5104 | N | 51 | X | SS | LND | 5104 |  | Check Roof - Cladding | ChSK |  |  |  |  |  |  |  |  |  |  |  |  |
| XN605501 |  | CA55 SR5501 - Install Gratings |  | 10d | 2011-06-10 A | 2011-07-14 A | XN205501, XN405501 SS, XE405501 | 100% |  | 2011-08-22 | 2011-09-01 |  |  |  |  | Grating [25 sqm]; Grating [93.75 h] |  | 93,75 | XN605501 | x | 93,75 | 0 | 934 | XNK | 55 | 200 | 200 | C | LND |  | X | N | XN60 | 5501 | N | 55 | X | SS | LND | 5501 |  | Check Roof - Cladding | ChSK |  |  |  |  |  |  |  |  |  |  |  |  |
| XN605401 |  | CA54 SR5401 - Install Gratings |  | 10d | 2011-06-20 A | 2011-07-28 A | XN405401 SS | 100% |  | 2011-07-25 | 2011-08-04 |  |  |  |  | Grating [45 sqm]; Grating [168.75 h] | 1,241.67 | 168,00 | XN605401 | x | 168,75 | 142 | 934 | XNK | 54 | 200 | 200 | C | LND |  | X | N | XN60 | 5401 | N | 51 | X | SS | LND | 5401 |  | Check Roof - Cladding | ChSK |  |  |  |  |  |  |  |  |  |  |  |  |
| XN713102 |  | CA31 Warehouse SK3102_01 - Steel Deliveries | milestone | 0d | 2011-06-30 A | 2011-06-30 A |  | 100% |  |  |  |  |  | finish on 2011-06-30 | TB26 - 3 - Construction Normal 7days * CA17 |  |  | 22t | XN713102 |  | 0 | 0 | 934 | XNK | 31 | 200 | 200 | C | LND | SD | X | N | XN06 | 3140 | N | 31 | X | SS | LND | 3140 |  |  |  |  |  |  |  |  |  |  |  |  |  |  |  |
| XN733102 |  | CA31 Warehouse SK3102_02-06 - Steel Deliveries | milestone | 0d | 2011-06-30 A | 2011-06-30 A |  | 100% |  |  |  |  |  | finish on 2011-06-30 | TB26 - 3 - Construction Normal 7days * CA17 |  |  | 22t | XN733102 |  | 0 | 0 | 934 | XNK | 31 | 200 | 200 | C | LND | SD | X | N | XN06 | 3140 | N | 31 | X | SS | LND | 3140 |  |  |  |  |  |  |  |  |  |  |  |  |  |  |  |
| XN753102 |  | CA31 Warehouse SK3102_40 - Steel Deliveries (welded sections) | milestone | 0d | 2011-07-15 A | 2011-07-15 A |  | 100% |  |  |  |  |  | finish on 2011-07-15 | TB26 - 3 - Construction Normal 7days * CA17 |  |  | 22t | XN753102 |  | 0 | 0 | 934 | XNK | 31 | 200 | 200 | C | LND | SD | X | N | XN06 | 3140 | N | 31 | X | SS | LND | 3140 |  |  |  |  |  |  |  |  |  |  |  |  |  |  |  |
| XN203140 |  | CA31 Warehouse SK3102 - Install Primary Steel (Roof) |  | 34d | 2011-09-07 | 2011-10-15 | P3N02ЦN (other project), XC40314015 FS+16d |  |  |  |  | -29d | 36d |  |  | Piperacks, Main Structures [550 t]; Piperacks, Main structures [23375 h] | 935,000 | 23375,00 | XN203140 |  | 23375 | 0 | 934 |  | 31 | 200 | 200 | C | LND | D | X | N | XN80 | 3140 | N | 31 | X | SS | LND | 3140 |  | Check Roof - Cladding | OMUS-1 |  |  | 182>380 |  |  |  |  |  |  |  |  |  |
| XN405502 |  | CA55 SR5502 - Install Railings,Ladders,etc. |  | 20d | 2011-09-29 | 2011-10-21 | XN205502 |  |  |  |  | 205d | 227.5d |  |  | Ladders & platforms [1 t]; Ladders & platforms [100 h] | 362.15 | 100,00 | XN405502 | x | 100 | 0 | 934 | XNK | 55 | 200 | 200 | C | LND |  | X | N | XN40 | 5502 | N | 55 | X | SS | LND | 5502 |  | Check Roof - Cladding | ChSK |  |  |  |  |  |  |  |  |  |  |  |  |
| XN803140 |  | CA31 Warehouse SK3102 - Install Cladding Walls&Roof |  | 60d | 2011-11-12 | 2012-01-27 | P3N02ЦN (other project), XC40314015, XN803110 FS-50d, P3N03N (other project), XC603140 FS-40d, XN203140 SS+20d |  |  |  |  | -65d | 0d | start on or after 2011-11-01 |  | Cladding [9950 sqm]; Cladding [49750 h] | 1,990,000 | 49750,00 | XN803140 |  | 49750 | 0 | 934 |  | 31 | 200 | 200 | C | LND | D | X | N | XN80 | 3140 | N | 31 | X | SS | LND | 3140 |  | Check Roof - Cladding | OMUS-1 |  |  |  |  |  |  |  |  |  |  |  |  |
| XN203140S |  | CA31 Warehouse SK3102 - Install Primary Steel (Roof) Southern of Silo Structure |  | 12d | 2011-11-30 | 2011-12-13 | XN803110S, XC40314015 SS+40d, P3N02ЦN (other project), XC40314020 |  |  |  |  | -53d | 0d |  |  | Piperacks, Main Structures [115 t]; Piperacks, Main structures [4887.5 h] | 195,500 | 4887,50 | XN203140S |  | 4887,5 | 0 | 934 |  | 31 | 200 | 200 | C | LND | D | X | N | XN80 | 3140 | N | 31 | X | SS | LND | 3140 |  | Check Roof - Cladding | OMUS-1 |  |  | 115 |  |  |  |  |  |  |  |  |  |
| XN803140S |  | CA31 Warehouse SK3102 - Install Cladding Roof (South of Silo Structure) |  | 33d | 2011-12-14 | 2012-01-27 | XC40314015, P3N02ЦN (other project), XC603140 FS-40d, XN203140S, P3N03N (other project), XN803140 SS |  |  |  |  | -53d | 0d | start on or after 2011-11-01 |  | Cladding |  | 0,00 | XN803140S |  | 0 | 0 | 934 |  | 31 | 200 | 200 | C | LND | D | X | N | XN80 | 3140 | N | 31 | X | SS | LND | 3140 |  | Check Roof - Cladding | OMUS-1 |  |  |  |  |  |  |  |  |  |  |  |  |
| A1010300 |  | CA54 SR5402 - Install Railings,Ladders,etc. |  | 20d | 2011-12-20 | 2012-01-18 | XN205601 FS-5d |  |  |  |  | 136d | 163.5d |  |  | Ladders & platforms [1 t]; Ladders & platforms [400 h] | 362.15 | 400,00 | A1010300 | Missing CB | 400 | 0 | 934 | XNK | 56 | 200 | 200 | C | LND |  | X | N | XN40 | 5601 | N | 51 | X | SS | LND | 5104 |  | Check Roof - Cladding | OMUS-1 |  |  |  |  |  |  |  |  |  |  |  |  |
| XN303140 |  | CA31 Warehouse SK3102 - Install Eqpt Platforms |  | 60d | 2012-02-22 | 2012-05-04 | XN733102 FS+10d, XN723102, XN713102 FS+10d, XN703102, IMS-C-000150 FF, XB003140 FF, P3N02ЦN (other project), XM003140 FF, EN283100 (other project) FF |  |  |  |  | 273.5d | 0d |  |  | Ladders & platforms [6 t]; Ladders & platforms [300 h] | 2,158.14 | 300,00 | XN303140 |  | 300 | 0 | 934 | XNK | 31 | 200 | 200 | C | LND |  | X | N | XN30 | 3140 | N | 31 | X | SS | LND | 3140 |  | Check Roof - Cladding | OMUS-1 |  |  |  | t |  |  |  |  |  |  |  |  |
| XN403140 |  | CA31 Warehouse SK3102 - Install Railings,Ladders,etc. |  | 45d | 2012-03-19 | 2012-05-11 | XN303140 FF+5d |  |  |  |  | 273.5d | 0d |  |  | Ladders & platforms [3 t]; Ladders & platforms [300 h] | 362.15 | 300,00 | XN403140 |  | 300 | 0 | 934 | XNK | 31 | 200 | 200 | C | LND |  | X | N | XN40 | 3140 | N | 31 | X | SS | LND | 3140 |  | Check Roof - Cladding | OMUS-1 |  |  |  |  |  |  |  |  |  |  |  |  |
| XN603140 |  | CA31 Warehouse SK3102 - Install Gratings |  | 40d | 2012-03-24 | 2012-05-11 | IMS-C-000150 FF, XN403140 FF, PN693140 (other project) FS+20d |  |  |  |  | 273.5d |  |  |  | Grating [40 sqm]; Grating [150 h] | 1,241.67 | 150,00 | XN603140 |  | 150 | 0 | 934 | XNK | 31 | 200 | 200 | C | LND |  | X | N | XN60 | 3140 | N | 31 | X | SS | LND | 3140 |  | Check Roof - Cladding | OMUS-1 |  |  |  |  |  |  |  |  |  |  |  |  |
|  | H | **HVAC** |  |  | 2011-12-23 | 2012-06-27 |  |  |  |  |  |  |  |  |  |  |  |  |  |  |  |  |  |  |  |  |  |  |  |  |  |  |  |  |  |  |  |  |  |  |  |  |  |  |  |  |  |  |  |  |  |  |  |  |  |
| XH00314005 |  | CA31 Warehouse - Installation HVAC |  | 110d | 2011-12-23 | 2012-05-10 | P3H01ST (other project), XC603140 FS-30d, XH000000 FF, EH30314005 (other project), XN203140 FS-5d, XN803140 SS, XC503140_1 |  |  |  |  | 50d | 0d |  |  | HVAC - Warehouse CA31 [7311 mhr]; HVAC - Warehouse CA31 [7311 h] |  | 7311,00 | XH00314005 |  | 7311 | 0 | 934 |  | 31 | 200 | 200 | C | LND |  | X | H | XH00 | 3100 | H | 31 | X | hvac | LND | 3140 |  |  | ARMO |  |  |  |  | x | REL XC50 | 2011-08-20 | 2011-11-10 | P | 2011-08-02 | 2011-10-26 | 31 |
| XH00314010 |  | CA31 Warehouse - Testing/Commissiong HVAC (Start w. temp. Power) |  | 70d | 2012-04-04 | 2012-06-27 | XH000C10, XH00314005 FS-30d, X0300008 FS+20d, XH000010 FF |  |  |  |  | 50d | 0d |  |  |  |  |  | XH00314010 |  | 0 | 0 | 934 |  | 31 | 200 | 200 | C | LND |  | X | H | XH20 | 3140 | H | 31 | X | hvac | LND | 3140 |  |  | ARMO |  |  |  |  |  |  | 2011-10-30 | 2012-01-31 | P | 2011-10-03 | 2011-12-08 |  |
| XH00314007 |  | CA31 Warehouse - HVAC ready for Heating | milestone | 0d | 2012-04-16 | 2012-04-16 | XH00314010 SS+10d |  |  |  |  | 294.5d | 150.5d |  |  |  |  | 2925 | XH00314007 |  | 0 | 0 | 934 |  | 31 | 200 | 200 | C | LND |  | X | H | XH00 | 3140 | H | 31 | X | hvac | LND | 3140 |  |  | ARMO |  |  |  |  |  |  |  |  |  | 2011-10-14 | 2011-10-14 |  |

Notes:
- XN713102: Scope: 09.02.2011: weight: 25 ton
- XN733102: Scope: 09.02.2011: weight:
- XN753102: Scope: 09.02.2011: weight: 470 ton
- XN203140: Current Status: XN203140 / CA31 Warehouse SK3102 - Install Primary Steel / (Roof) / 45 / MN0A / 242 / t / LN0D / 10285 / h / NEW / XN203140 / CA31 Warehouse SK3102 - Install Primary Steel / (Roof) / 35 / MN0A / 182 / t / 75% / 181,5 / LN0D / 7714 / h / 7713,75 / XN203140S / CA31 Warehouse SK3102 - Install Primary Steel (Roof) / Southern of Silo Structure / 12 / MN0A / 60 / t / 25% / 60,5 / LN0D / 2572 / h / 2571,25
- XN803140: Current Status: XN803140 / CA31 Warehouse SK3102 - Install Cladding / Walls&Roof / 80 / MN0D / 10550 / sqm / LN0D / 52750 / h / NEW / XN803140 / CA31 Warehouse SK3102 - Install Cladding / Walls&Roof / 60 / MN0D / 7910 / sqm / 75% / 7912,5 / LN0D / 39560 / h / 39562,5 / XN803140S / CA31 Warehouse SK3102 - Install Cladding Roof (South of Silo / Structure) / 20 / MN0D / 2640 / sqm / 25% / 2637,5 / LN0D / 13190 / h / 13187,5
- XN203140S: Current Status: 110131 Installation of roof in warehouse (3102) not before completion of / cladding silo structure warehouse / XN203140 / CA31 Warehouse SK3102 - Install Primary Steel / (Roof) / 45 / MN0A / 242 / t / LN0D / 10285 / h / NEW / XN203140 / CA31 Warehouse SK3102 - Install Primary Steel / (Roof) / 35 / MN0A / 182 / t / 75% / 181,5 / LN0D / 7714 / h / 7713,75 / XN203140S / CA31 Warehouse SK3102 - Install Primary Steel (Roof) / Southern of Silo Structure / 12 / MN0A / 60 / t / 25% / 60,5 / LN0D / 2572 / h / 2571,25
- XN803140S: Current Status: 2110806 Delivery in November 2011 (Info from Fr. Schilka / 02.08.2011) / 110131 Installation of roof in warehouse (3102) not before completion of / cladding silo structure warehouse / XN803140 / CA31 Warehouse SK3102 - Install Cladding / Walls&Roof / 80 / MN0D / 10550 / sqm / LN0D / 52750 / h / NEW / XN803140 / CA31 Warehouse SK3102 - Install Cladding / Walls&Roof / 60 / MN0D / 7910 / sqm / 75% / 7912,5 / LN0D / 39560 / h / 39562,5 / XN803140S / CA31 Warehouse SK3102 - Install Cladding Roof (South of Silo / Structure) / 20 / MN0D / 2640 / sqm / 25% / 2637,5 / LN0D / 13190 / h / 13187,5

| ID | WBS | Activity | Duration | Start | Finish | Predecessors | Complete | Remaining | Planned start | Planned finish | Total float | Free float | Constraint | Calendar | Resources | Cost | Actual cost | TB26 Ressource Budget | UDF_CONTRACT START DATE | UDF_CONTRACT FINISH DATE | UDF_CONTRACT ITEM | UDF_CONTRACT DATE PENALIZED | UDF_PENALIZED START | UDF_PENALIZED FINISH | UDF_SAVE ACT ID | UDF_BUDGETED LABOR UNIT | UDF_ACTUAL LABOR UNIT | Department | Type of Work | Constr. Area | Inquiry/Order No | PMT-Area | PMT-Schedule Org | PMT-Phase | PMT-Respons. | WBS Phase | WBS Discipline | WBS Type of Work | WBS Objects | Russia WBS Discipline (Russia) | Russia Construction Area | Russia WBS Phase | IMS | UPT | Russia WBS Objects | Subcontractor | Filter | UDF_CONTRACT INDICATOR | UDF_PLANNED START | UDF_SELECT UPDATE PROGRESS | UDF_CHECK RESOURCE DATES | UDF_PLANNED FINISH | UDF_CONTRACT FINISH DATE REV1 | UDF_CONTRACT START DATE REV1 | UDF_INDICATOR | TB26 Semantics | TB26 Material Res Values | UDF_ELECTRICAL START | UDF_ELECTRICAL FINISH | UDF_CHECK BASELINE | geplanter Start | geplantes Ende |
| --- | --- | --- | --- | --- | --- | --- | --- | --- | --- | --- | --- | --- | --- | --- | --- | --- | --- | --- | --- | --- | --- | --- | --- | --- | --- | --- | --- | --- | --- | --- | --- | --- | --- | --- | --- | --- | --- | --- | --- | --- | --- | --- | --- | --- | --- | --- | --- | --- | --- | --- | --- | --- | --- | --- | --- | --- | --- | --- | --- | --- | --- | --- |
|  | U | **Package Units** |  |  |  |  |  |  |  |  |  |  |  |  |  |  |  |  |  |  |  |  |  |  |  |  |  |  |  |  |  |  |  |  |  |  |  |  |  |  |  |  |  |  |  |  |  |  |  |  |  |  |  |  |  |  |  |  |  |  |  |  |
|  | B | **Mechanical - Stationary Equipment** |  | 2012-01-17 | 2012-05-04 |  |  |  |  |  |  |  |  |  |  |  |  |  |  |  |  |  |  |  |  |  |  |  |  |  |  |  |  |  |  |  |  |  |  |  |  |  |  |  |  |  |  |  |  |  |  |  |  |  |  |  |  |  |  |  |  |  |
| XB003140 |  | CA31 Warehouse -Install Pallet/Packaging St.Eqpt | 91d | 2012-01-17 | 2012-05-04 | P3U07S (other project), IMS-C-000165 FF, XC603140, P3A12S2 (other project), XN803140S FS-10d |  |  |  |  | -53d | 0d |  |  | Packaging lines [9500 mhr]; Packaging lines [9500 h] | 950,000 |  | 9500,00 | 2011-08-01 | 2012-02-15 | E-08-01-20 | P | 2012-02-15 | 2012-02-15 | XB003140 | 9500 | 0 | 934 | XBB | 31 | 2DC9020 | 200 | 200 | C | LND | X | B | XB00 | 3140 | B | 31 | X | EQ | LND | 3140 | OMUS-1 |  |  |  |  |  |  |  |  |  |  |  |  |  |  |  |  |
|  | M | **Mechanical - Rotating Equipment** |  | 2012-01-30 | 2012-04-27 |  |  |  |  |  |  |  |  |  |  |  |  |  |  |  |  |  |  |  |  |  |  |  |  |  |  |  |  |  |  |  |  |  |  |  |  |  |  |  |  |  |  |  |  |  |  |  |  |  |  |  |  |  |  |  |  |  |
| XM003140 |  | CA31 Warehouse -Install Pallet/Packaging RotEqpt | 75d | 2012-01-30 | 2012-04-27 | XC603140, P3U07S (other project), XB003140 SS, XN803140S FS-10d |  |  |  |  | -48d | 0d | as late as possible |  |  |  |  |  | 2011-08-01 | 2011-10-30 | E-08-01-20 | P | 2012-02-15 | 2012-02-15 | XM003140 | 0 | 0 | 934 | XBB | 31 | 2DC9020 | 200 | 200 | C | LND | X | M | XM00 | 3140 | M | 31 | X | EQ | LND | 3140 | OMUS-1 |  |  |  |  |  |  |  |  |  |  |  |  |  |  |  |  |
|  | R | **Piping** |  | 2011-07-18 | 2012-05-31 |  |  |  |  |  |  |  |  |  |  |  |  |  |  |  |  |  |  |  |  |  |  |  |  |  |  |  |  |  |  |  |  |  |  |  |  |  |  |  |  |  |  |  |  |  |  |  |  |  |  |  |  |  |  |  |  |  |
| XR203140 |  | CA31 Warehouse - Piping Prefabrication | 100d | 2011-07-18 A | 2011-12-22 | ER49314005 (other project) SS+18d, IMS-C-000180 FF, ER493140 (other project) SS+18d |  | 100d | 2011-11-25 | 2012-03-29 | -15d | 93d |  |  | A/G piping prefabrication [1700 Fpi]; A/G Piping (Prefab) [6375 h] | 32,379.45 |  | 6375,00 |  |  |  |  |  |  | XR203140 | 6375 | 0 | 934 |  | 31 |  | 200 | 200 | C | LND | X | R | XR20 | 3140 | R | 31 | X | PRP | LND | 3140 | OMUS-1 | 1 | UDF_G4 |  |  |  |  |  |  |  |  |  |  |  |  |  |  |
| XR403140 |  | CA31 Warehouse - Piping Installation | 128d | 2011-11-24 | 2012-04-30 | IMS-C-000190 FF, P3S06S (other project) FF+20d, XR203140 SS+60d, XR203140 FF+10d, XN803140 SS+10d, P3J04CS1 (other project), P3J04IS (other project) |  |  |  |  | -65d | 0d |  |  | A/G piping field installation [2090 Fpi]; Control & Shut-off valves [14 pcs]; Install Control & Shut-off Valves [73.5 h]; A/G Piping (Field) [13062.5 h]; Deluge Piping [8700 Fpi]; Deluge piping [54375 h] | 2,293,075.13 |  | 67511,00 | 2011-03-01 | 2012-01-30 | E-06-03-08 |  |  |  | XR403140 | 67511 | 0 | 934 |  | 31 |  | 200 | 200 | C | LND | X | R | XR40 | 3140 | R | 31 | X | PI | LND | 3140 | OMUS-1 |  |  | 2011-06-28 | 27.8. | x |  |  |  |  |  |  |  |  |  |  |  |
| XR603140 |  | CA31 Warehouse - Piping Pressure Tests | 50d | 2012-03-27 | 2012-05-25 | XR403140 FF+20d |  |  |  |  | -65d | 0d |  |  |  |  |  | 1436 | 2011-03-01 | 2012-01-30 | E-06-03-08 |  |  |  | XR603140 | 0 | 0 | 934 |  | 31 |  | 200 | 200 | C | LND | X | R | XR60 | 3140 | R | 31 | X | HY | LND | 3140 | OMUS-1 |  |  |  |  |  |  |  |  |  |  |  |  |  |  |  |  |
| XR803140 |  | CA31 Warehouse - Piping Reinstatement | 30d | 2012-04-25 | 2012-05-31 | XR603140 FF+5d, IMS-C-000360 FF |  |  |  |  | -65d | 0d |  |  |  |  |  | 718 | 2011-03-01 | 2012-01-30 | E-06-03-08 |  |  |  | XR803140 | 0 | 0 | 934 |  | 31 |  | 200 | 200 | C | LND | X | R | XR80 | 3140 | R | 31 | X | PI | LND | 3140 | OMUS-1 |  |  |  |  |  | 2012-05-28 |  |  |  |  |  |  |  |  |  |  |
|  | E | **Electrical** |  | 2010-06-28 | 2012-09-03 |  |  |  |  |  |  |  |  |  |  |  |  |  |  |  |  |  |  |  |  |  |  |  |  |  |  |  |  |  |  |  |  |  |  |  |  |  |  |  |  |  |  |  |  |  |  |  |  |  |  |  |  |  |  |  |  |  |
| XC913140 |  | CA31 Warehouse - Earthing&Lightn.System_CIVIL | 74d | 2010-06-28 A | 2010-09-21 A | EE903140 (other project), XC203140 SS | 100% |  |  |  |  |  |  |  | Grounding & Lightning [1020 pcs]; Grounding & Lightning [11475 h] | 459,000 | 459,000 | 11475,00 | 2011-09-10 | 2012-01-30 | E-16-07-14 |  |  |  | XC913140 | 11475 | 11475 | 934 |  | 31 |  | 200 | 200 | C | LND | X | C | XE91 | 3140 | C | 31 | X | EA | LND | 3140 | MO11 |  |  |  |  |  |  |  |  |  |  |  |  |  |  |  |  |
| XE913140 |  | CA31 Warehouse - Earthing&Lightn.System_E/I | 15d | 2012-01-28 | 2012-02-14 | XN803140 |  |  |  |  | 113d | 208d |  |  |  |  |  | 1140 | 2011-09-10 | 2012-01-30 | E-16-07-14 |  |  |  | XE913140 | 0 | 0 | 934 |  | 31 |  | 200 | 200 | C | LND | X | E | XE91 | 3140 | E | 31 | X | EA | LND | 3140 | URMA |  |  |  |  |  |  | 2012-05-30 | 2011-12-01 | UDF_G2 |  |  |  |  |  |  |  |
| XE403140 |  | CA31 Warehouse - Install Cable Trays | 40d | 2012-03-15 | 2012-04-30 | XR403140 FS-40d, XN803140, XN803140S, EE46314010 (other project) |  |  |  |  | -40d | 0d |  |  | Cable trays/conduits [2740 m]; Cable trays [8220 h] | 328,800 |  | 8220,00 | 2011-06-30 | 2011-10-30 | E-15-01-13 |  |  |  | XE403140 | 8220 | 0 | 934 |  | 31 |  | 200 | 200 | C | LND | X | E | XE40 | 3140 | E | 31 | X | EL | LND | 3140 | URMA |  |  |  |  |  |  | 2012-02-15 | 2011-10-01 | UDF_G2 | m | 2900 | 2011-11-14 | 2012-01-28 | x |  |  |
| XE343140 |  | CA31 Warehouse - Install Local Operation Panels | 50d | 2012-04-07 | 2012-06-06 | EE46314010 (other project), XE403140 FS-20d, XR403140 FS-40d |  |  |  |  | 251.5d |  |  |  | Field Panels [52 pcs]; Field panels [1040 h] | 41,600 |  | 1040,00 | 2011-09-10 | 2012-01-30 | E-16-07-14 |  |  |  | XE343140 | 1040 | 0 | 934 |  | 31 |  | 200 | 200 | C | LND | X | E | XE34 | 3140 | E | 31 | X | EL | LND | 3140 | URMA |  |  |  |  |  |  | 2012-05-30 | 2011-12-01 | UDF_G2 |  |  |  |  |  |  |  |
| XE703140 |  | CA31 Warehouse - Install Lighting & Small Power | 60d | 2012-04-07 | 2012-06-19 | XH00314005 SS+20d, P3E09S (other project), XN803140, P3E03S2 (other project), XP341610 FS+50d, XN803140S, XE403140 FS-20d |  |  |  |  | 10d | 0d |  |  | Cable Pulling [3000 m]; Lighting illuminates [520 pcs]; Lighting (iluminates) [5200 h]; Cable pulling [1500 h] | 268,000 |  | 6700,00 | 2011-05-10 | 2012-01-31 | E-16-03-01 |  |  |  | XE703140 | 6700 | 0 | 934 |  | 31 |  | 200 | 200 | C | LND | X | E | XE70 | 3140 | E | 31 | X | EL | LND | 3140 | URMA | x |  |  |  |  |  | 2012-05-10 | 2011-08-15 | UDF_G2 |  |  |  |  |  |  |  |
| XE503140 |  | CA31 Warehouse - Cable Pulling Electric | 50d | 2012-06-07 | 2012-08-04 | XE503130 FS-30d, P3E15CS (other project), P3E15BS (other project), XE403140 FS-20d, P3E15AS (other project), XE500C01, EE563140 (other project), XE505601 SS |  |  |  |  | -55d | 0d |  | TB26 - V - Construct-Winter partly * | Cable Pulling [12100 m]; Cable pulling [6050 h] | 242,000 |  | 6050,00 | 2011-05-20 | 2012-02-10 | E-16-01-01 |  |  |  | XE503140 | 6050 | 0 | 934 |  | 31 |  | 200 | 200 | C | LND | X | E | XE50 | 3140 | E | 31 | X | EL | LND | 3140 | URMA |  |  |  |  |  |  | 2012-07-01 | 2011-10-01 | UDF_G2 | m | 12500 | 2011-12-28 | 2012-03-02 |  |  |  |
| XE923140 |  | CA31 Warehouse - Install Fire Detection System | 60d | 2012-06-20 | 2012-08-28 | XJ423140, XC503140, XH00314005, XE703140 |  |  |  |  | 181.5d | 0d |  |  | Fire Detection System; Fire detection system |  |  | 0,00 |  |  |  |  |  |  | XE923140 | 0 | 0 | 934 |  | 31 |  | 200 | 200 | C | UIO | X | E | XE92 | 3140 | E | 31 | X | FGDS | LND | 3130 |  | x |  |  |  |  |  |  |  | UDF_G2 |  |  |  |  | x | 2012-02-14 | 2012-06-27 |
| XE963140 |  | CA31 Warehouse - Install Communication System | 60d | 2012-06-20 | 2012-08-28 | XJ423140, XH00314005, XE703140, XE923140 SS, E3E1350 (other project), XC503140 |  |  |  |  | 181.5d |  |  |  | Communication System |  |  | 0,00 |  |  |  |  |  |  | XE963140 | 0 | 0 | 934 |  | 31 |  | 200 | 200 | C | LND | X | E | XE96 | 3140 | E | 31 | X | CS | LND | 3130 |  | x |  |  |  |  |  |  |  | UDF_G2 |  |  |  |  | x | 2012-02-14 | 2012-06-27 |
| XE603140 |  | CA31 Warehouse - Cable Termination & Testing | 50d | 2012-07-07 | 2012-09-03 | XE503140 FS-25d, IMS-C-000260 FF, IMS-C-000390 FF |  |  |  |  | -55d | 32.5d |  |  | Cable connecting [210 pcs]; Cable connecting [525 h] | 21,000 |  | 525,00 | 2011-04-20 | 2011-11-30 | E-16-02-01 |  |  |  | XE603140 | 525 | 0 | 934 |  | 31 |  | 200 | 200 | C | LND | X | E | XE60 | 3140 | E | 31 | X | ET | LND | 3140 | URMA |  |  |  |  |  |  | 2012-08-14 | 2011-12-10 | UDF_G2 |  |  |  |  |  |  |  |
|  | J | **Instrumentation** |  | 2012-03-13 | 2012-10-29 |  |  |  |  |  |  |  |  |  |  |  |  |  |  |  |  |  |  |  |  |  |  |  |  |  |  |  |  |  |  |  |  |  |  |  |  |  |  |  |  |  |  |  |  |  |  |  |  |  |  |  |  |  |  |  |  |  |
| XJ323140 |  | CA31 Warehouse - Install Junction Boxes | 30d | 2012-03-13 | 2012-04-16 | XM003140 FS-40d, P3J06ES (other project) FS+14d, P3J06FS (other project), EJ323140 (other project), XB003140 FS-45d, XR403140 FS-60d |  |  |  |  | -38d | 2d |  |  | Junction Boxes/Cabinets/Panels [37 pcs]; Install Junction Boxes/ Cabinets/ Panels [925 h] | 37,000 |  | 925,00 | 2011-09-10 | 2012-04-20 | E-17-04-14 |  |  | 2012-07-10 | XJ323140 | 925 | 0 | 934 |  | 31 |  | 200 | 200 | C | LND | X | J | XJ32 | 3140 | J | 31 | X | IN | LND | 3140 | URMA |  |  |  |  |  |  | 2012-07-10 | 2012-01-01 | UDF_G2 |  |  |  |  |  |  |  |
| XJ423140 |  | CA31 Warehouse - Install Secondary Cable Trays | 30d | 2012-04-07 | 2012-05-14 | XJ323140 FS-10d, EJ46314010 (other project), XE403140 FS-20d, XR403140 FS-60d |  |  |  |  | -40d | 0d |  |  | Secondary cable trays [350 m]; Install secondary cable trays [1312.5 h] | 52,500 |  | 1312,50 | 2011-06-30 | 2011-10-30 | E-15-01-13 |  |  |  | XJ423140 | 1312,5 | 0 | 934 |  | 31 |  | 200 | 200 | C | LND | X | J | XJ42 | 3140 | J | 31 | X | IN | LND | 3140 | URMA | x |  |  |  |  |  | 2012-02-15 | 2011-10-01 | UDF_G2 | m | 540 | 2011-11-25 | 2012-01-28 | x |  |  |
| XJ443140 |  | CA31 Warehouse - Install Conduits to Instrm | 40d | 2012-04-25 | 2012-06-13 | XJ323140 FS-15d, XE403140 FS-20d, XJ423140 FS-15d, XR403140 FS-60d |  |  |  |  | -40d | 25d |  |  |  |  |  |  | 2011-09-10 | 2012-04-20 | E-17-04-14 |  |  | 2012-07-10 | XJ443140 | 0 | 0 | 934 |  | 31 |  | 200 | 200 | C | LND | X | J | XJ44 | 3140 | J | 31 | X | IN | LND | 3140 | URMA |  |  |  |  |  |  | 2012-07-10 | 2012-01-01 | UDF_G2 |  |  |  |  |  |  |  |
| XJ303140 |  | CA31 Warehouse - Install Field Instruments | 50d | 2012-05-21 | 2012-07-18 | XR403140 FS-6d, P3J05S (other project), IMS-C-000340 FF, EJ363140 (other project), XR803140 FS-10d, XB003140, XM003140 |  |  |  |  | -65d | 0d |  |  | Field Instruments [51 pcs]; Install field instruments [280 h] | 11,220 |  | 280,00 | 2011-09-10 | 2012-04-20 | E-17-04-14 | x |  | 2012-07-10 | XJ303140 | 280 | 0 | 934 |  | 31 |  | 200 | 200 | C | LND | X | J | XJ30 | 3140 | J | 31 | X | IN | LND | 3140 | URMA |  |  |  |  |  |  | 2012-07-10 | 2012-01-01 | UDF_G2 |  |  |  |  |  |  |  |
| XJ393140 |  | CA31 Warehouse - Install Earthing Field Eqpt | 20d | 2012-06-20 | 2012-07-12 | XJ303140 FS-25d, XJ423140 FS-15d, XJ443140 FS-20d |  |  |  |  | -50d | 15d |  |  |  |  |  |  | 2011-09-10 | 2012-04-20 | E-17-04-14 |  |  | 2012-07-10 | XJ393140 | 0 | 0 | 934 |  | 31 |  | 200 | 200 | C | LND | X | J | XJ39 | 3140 | J | 31 | X | IN | LND | 3140 | URMA |  |  |  |  |  |  | 2012-07-10 | 2012-01-01 | UDF_G2 |  |  |  |  |  |  |  |
| XJ543140 |  | CA31 Warehouse - Pulling Singlecore Cables | 50d | 2012-06-20 | 2012-08-16 | XJ303140 FS-25d, XJ423140 FS-10d, XE500C01, X3J130 FF, EJ803140 (other project), XJ443140 FS-20d |  |  |  |  | -65d | 0d |  | TB26 - V - Construct-Winter partly * | Singlecore cables [3500 m]; Pull singlecore cables [2625 h] | 105,000 |  | 2625,00 | 2011-09-10 | 2012-04-20 | E-17-04-14 |  |  | 2012-07-10 | XJ543140 | 2625 | 0 | 934 |  | 31 |  | 200 | 200 | C | LND | X | J | XJ54 | 3140 | J | 31 | X | IN | LND | 3140 | URMA |  |  |  |  |  |  | 2012-07-10 | 2012-01-01 | UDF_G2 | m | 3380 | 2012-02-10 | 2012-04-10 |  |  |  |
| XJ703140 |  | CA31 Warehouse - Instrument Tubing | 40d | 2012-06-26 | 2012-08-10 | XJ303140 FS-20d |  |  |  |  | -65d | 0d |  |  |  |  |  |  | 2011-09-10 | 2012-04-20 | E-17-04-14 |  |  | 2012-07-10 | XJ703140 | 0 | 0 | 934 |  | 31 |  | 200 | 200 | C | LND | X | J | XJ70 | 3140 | J | 31 | X | IN | LND | 3140 | URMA |  |  |  |  |  |  | 2012-07-10 | 2012-01-01 | UDF_G2 |  |  |  |  |  |  |  |
| XJ643140 |  | CA31 Warehouse - Termin Singlecore Cables | 50d | 2012-07-19 | 2012-09-14 | XJ543140 FS-25d, XJ303140 FS-25d, XJ323140 FS-10d, XJ393140 FS-10d, XJ703140 FS-20d |  |  |  |  | -65d | 22.5d |  |  | Termination Field [2145 mhr]; Termination field [2145 h] | 214,500 |  | 2145,00 | 2011-09-10 | 2012-04-20 | E-17-04-14 |  |  | 2012-07-10 | XJ643140 | 2145 | 0 | 934 |  | 31 |  | 200 | 200 | C | LND | X | J | XJ64 | 3140 | J | 31 | X | IN | LND | 3140 | URMA |  |  |  |  |  |  | 2012-07-10 | 2012-01-01 | UDF_G2 |  |  |  |  |  |  |  |
| XJ523140 |  | CA31 Warehouse - Pulling Multicore Cables | 40d | 2012-07-27 | 2012-09-12 | XJ323140 FS-10d, XJ523130 FS-30d, XE500C01, XJ525601 FS-10d, XE403140 FS-20d |  |  |  |  | -82.5d | 0d |  | TB26 - V - Construct-Winter partly * | Multicore cables [2700 m]; Pull multicore cables [1350 h] | 54,000 |  | 1350,00 | 2011-05-20 | 2012-03-10 | E-17-01-01 |  |  |  | XJ523140 | 1350 | 0 | 934 |  | 31 |  | 200 | 200 | C | LND | X | J | XJ52 | 3140 | J | 31 | X | IN | LND | 3140 | URMA |  |  |  |  |  |  | 2012-06-16 | 2011-11-01 | UDF_G2 | m | 1950 | 2012-01-18 | 2012-03-05 |  |  |  |
| XJ623140 |  | CA31 Warehouse - Termin Multicore Cables | 40d | 2012-08-20 | 2012-10-05 | XH00314005 FS-60d, XJ523140 FS-20d, XJ323140 FS-10d |  |  |  |  | -82.5d | 0d |  |  | Termination Field [2118 mhr]; Termination field [2118 h] | 211,800 |  | 2118,00 | 2011-05-20 | 2012-03-10 | E-17-01-01 |  |  |  | XJ623140 | 2118 | 0 | 934 |  | 31 |  | 200 | 200 | C | LND | X | J | XJ62 | 3140 | J | 31 | X | IN | LND | 3140 | URMA |  |  |  |  |  |  | 2012-06-16 | 2011-11-01 | UDF_G2 |  |  |  |  |  |  |  |
| XJ803140 |  | CA31 Warehouse - Inspections/ Mech. Acceptance/ Loop Checks | 40d | 2012-09-12 | 2012-10-29 | X3J120, IMS-C-000420 FF, XJ643140 FS-25d, XJ703140 FS-20d, X030410030, XJ393140 FS-10d, EJ803140 (other project), X3J100 FF, XJ623140 FS-20d, XE603140 FS-25d |  |  |  |  | -55.5d | 15d |  |  | Loop Checks [150 pcs]; Loop checks [750 h] | 30,000 |  | 750,00 | 2011-06-10 | 2012-04-30 | E-17-02-01 |  |  | 2012-08-18 | XJ803140 | 750 | 0 | 934 |  | 31 |  | 200 | 200 | C | LND | X | J | XJ80 | 3140 | J | 31 | X | LT | LND | 3140 | URMA |  |  |  |  |  |  | 2012-08-18 | 2012-03-01 | UDF_G2 |  |  |  |  |  |  |  |

Notes:
- XR403140: P3 Activity Log Info: Start with Fire Water System
- XE913140: UDF_PREDECESSOR: XN30, DEL XE40, DEL XE80, DEL XJ40, Civil 100%, Equipment 100%
- XE403140: UDF_PREDECESSOR: XN30, Piping 50%
- XE343140: UDF_PREDECESSOR: XE40, Equipment 100%, Piping 50%
- XE703140: UDF_PREDECESSOR: XE40, Civil 100%, HVAC ducts, Finishing works partly
- XE503140: UDF_PREDECESSOR: XE40, XE50, DEL XE34
- XE923140: Scope: CA31: / FDS - 146external sensors / Structured Cable System (SCS) / FOCL / DS + SAME / MDCN
- XE603140: UDF_PREDECESSOR: XE50, Equipment 100%
- XJ323140: UDF_PREDECESSOR: Civil 100%, Equipment 100%, Piping 50%
- XJ423140: UDF_PREDECESSOR: XE40, XJ32, Equipment 100%, Piping 50%
- XJ443140: UDF_PREDECESSOR: XE40, XJ32, XJ40, Equipment 100%, Piping 50%
- XJ303140: UDF_PREDECESSOR: XR80, XR40, Equipment 100%, Piping 50%
- XJ393140: UDF_PREDECESSOR: XJ30, XJ42, XJ44, DEL XJ32, DEL XR40
- XJ543140: UDF_PREDECESSOR: XJ30, XJ42, XJ44
- XJ703140: UDF_PREDECESSOR: XJ30
- XJ643140: UDF_PREDECESSOR: XJ30, XJ32, XJ39, XJ54, XJ70
- XJ523140: UDF_PREDECESSOR: XE40, XJ32, XJ52
- XJ623140: Current Status: 110803 (WL): PRED CA31 Warehouse - Installation HVAC - / lag 0 > lag -60 / UDF_PREDECESSOR: XJ32, XJ52
- XJ803140: UDF_PREDECESSOR: XE60, XJ39, XJ62, XJ64, XJ70

| ID | WBS | Activity | Type | Duration | Start | Finish | Predecessors | Remaining | Total float | Free float | Constraint | Calendar | Resources | Cost | TB26 Ressource Budget | UDF_SELECT UPDATE PROGRESS | UDF_SAVE ACT ID | UDF_BUDGETED LABOR UNIT | UDF_ACTUAL LABOR UNIT | UDF_CHECK RESOURCE DATES | Department | Constr. Area | PMT-Area | PMT-Schedule Org | PMT-Phase | PMT-Respons. | WBS Phase | WBS Discipline | WBS Type of Work | WBS Objects | Russia WBS Discipline (Russia) | Russia Construction Area | Russia WBS Phase | IMS | UPT | Russia WBS Objects | Subcontractor | Type of Work | UDF_COMMENTS_0827 | Inquiry/Order No | UDF_ELECTRICAL START | UDF_ELECTRICAL FINISH | UDF_CONTRACT START DATE | UDF_CONTRACT FINISH DATE | UDF_CONTRACT ITEM | TB26 Semantics | TB26 Material Res Values | UDF_CONTRACT FINISH DATE REV1 | UDF_CONTRACT START DATE REV1 | MTA | UDF_PENALIZED FINISH | UDF_CHECK BASELINE |
| --- | --- | --- | --- | --- | --- | --- | --- | --- | --- | --- | --- | --- | --- | --- | --- | --- | --- | --- | --- | --- | --- | --- | --- | --- | --- | --- | --- | --- | --- | --- | --- | --- | --- | --- | --- | --- | --- | --- | --- | --- | --- | --- | --- | --- | --- | --- | --- | --- | --- | --- | --- | --- |
|  | S | **Safety & Environment** |  |  |  |  |  |  |  |  |  |  |  |  |  |  |  |  |  |  |  |  |  |  |  |  |  |  |  |  |  |  |  |  |  |  |  |  |  |  |  |  |  |  |  |  |  |  |  |  |  |  |
|  | W | **Painting** |  |  | 2011-07-30 | 2011-10-08 |  |  |  |  |  |  |  |  |  |  |  |  |  |  |  |  |  |  |  |  |  |  |  |  |  |  |  |  |  |  |  |  |  |  |  |  |  |  |  |  |  |  |  |  |  |  |
| XW503140 |  | CA31 Warehouse - Surf.Protection Piping |  | 61d | 2011-07-30 A | 2011-10-08 | IMS-C-000200 FF | 37d | 263d | 333.5d |  |  | Piping painting [1809 sqm]; Piping painting [4523 h] | 2,768.62 | 4523,00 | 27.8. | XW503140 | 4523 | 0 | ok | 934 | 31 | 200 | 200 | C | LND | X | W | XW50 | 3140 | W | 31 | X | PA | LND | 3140 | OMUS-1 |  |  |  |  |  |  |  |  |  |  |  |  |  |  |  |
|  | V | **Insulation** |  |  |  |  |  |  |  |  |  |  |  |  |  |  |  |  |  |  |  |  |  |  |  |  |  |  |  |  |  |  |  |  |  |  |  |  |  |  |  |  |  |  |  |  |  |  |  |  |  |  |
|  | 32 | **CA32 - Container Yard** |  |  |  |  |  |  |  |  |  |  |  |  |  |  |  |  |  |  |  |  |  |  |  |  |  |  |  |  |  |  |  |  |  |  |  |  |  |  |  |  |  |  |  |  |  |  |  |  |  |  |
|  | 41 | **CA41 - Control Building** |  |  | 2011-09-23 | 2012-12-31 |  |  |  |  |  |  |  |  |  |  |  |  |  |  |  |  |  |  |  |  |  |  |  |  |  |  |  |  |  |  |  |  |  |  |  |  |  |  |  |  |  |  |  |  |  |  |
|  | 0B | **General Activities** |  |  | 2011-09-23 | 2012-12-31 |  |  |  |  |  |  |  |  |  |  |  |  |  |  |  |  |  |  |  |  |  |  |  |  |  |  |  |  |  |  |  |  |  |  |  |  |  |  |  |  |  |  |  |  |  |  |
| X020410010 |  | CA41 Control Bldg - Clearance Rooms by UI&O | milestone | 0d | 2011-09-23 | 2011-09-23 | F4550 |  | -84d | 0d | as late as possible |  |  |  |  |  | X020410010 | 0 | 0 |  | 934 | 41 | 200 | 200 | C | UIO | X | 0B | XC50 | 4100 | C | 16 | X | ML | OWN | 1610 |  |  |  |  |  |  |  |  |  |  |  |  |  |  |  |  |
| X020410015 |  | CA41 PipeRack to Control Bldg - Clearance by UI&O | milestone | 0d | 2012-06-09 | 2012-06-09 | F4550 |  | -195.5d | 0d | as late as possible |  |  |  |  |  | X020410015 | 0 | 0 |  | 934 | 41 | 200 | 200 | C | UIO | X | 0B | XC50 | 4100 | C | 16 | X | ML | OWN | 1610 |  |  |  |  |  |  |  |  |  |  |  |  |  |  |  |  |
| X0104110 |  | CA41 Control Bldg - Construction Completion | milestone | 0d | 2012-08-10 | 2012-08-10 | XE604100, XJ544100 |  | -40.5d | 71d |  | TB26 - 2 - Manuf and Delivy |  |  |  |  | X0104110 | 0 | 0 |  | 934 | 41 | 200 | 200 | C | LND | X | 0B | X010 | 4100 | 0 | 41 | X | MC | LND | 4100 |  | XNK |  |  |  |  |  |  |  |  |  |  |  |  |  |  |
| X030410030 |  | CA41 Control Bldg - LV available / Ready for Loop Checks | milestone | 0d | 2012-08-25 | 2012-08-25 | XE50161015 |  | -107.5d | 0d |  |  |  |  |  |  | X030410030 | 0 | 0 |  | 934 | 41 | 200 | 200 | C | LND | X | 0B | X000 | 4100 | 0 | 41 | X | DCS | OWN | 4100 |  | XNK |  |  |  |  |  |  |  |  |  |  |  |  |  |  |
| X0104100 |  | CA41 Control Bldg - Mechanical Completion | milestone | 0d | 2012-12-31 | 2012-12-31 | XJ804100 FF, XE604100, X0104110 |  | -126.5d | 0d |  | TB26 - 2 - Manuf and Delivy |  |  |  |  | X0104100 | 0 | 0 |  | 934 | 41 | 200 | 200 | C | LND | X | 0B | X010 | 4100 | 0 | 41 | X | MC | LND | 4100 |  | XNK |  |  |  |  |  |  |  |  |  |  |  |  |  |  |
|  | E | **Electrical** |  |  | 2011-09-30 | 2012-08-18 |  |  |  |  |  |  |  |  |  |  |  |  |  |  |  |  |  |  |  |  |  |  |  |  |  |  |  |  |  |  |  |  |  |  |  |  |  |  |  |  |  |  |  |  |  |  |
| XE204100 |  | CA41 Control Bldg - Install 10kV SwGears |  | 50d | 2011-09-30 | 2011-11-28 | X020410010 FS+5d, P3E01AS4 (other project), XE404100 FF |  | -84d | 0d | start on or after 2011-09-30 |  | Main Equipment Substations [33 pcs]; Installation main equipment substation [1237.5 h] | 49,500 | 1237,50 |  | XE204100 | 1237,5 | 0 |  | 934 | 41 |  |  |  | LND | X | E | XE20 | 4100 | E | 41 | X | SS | LND | 4100 | URMA | E01A | to be checked | 2EB5640 |  |  |  |  |  |  |  |  |  |  |  |  |
| XE404100 |  | CA41 Control Bldg - Install Cable Trays by UI&O |  | 50d | 2011-09-30 | 2011-11-28 | X020410010, X020410050 |  | -84d | 0d | as late as possible |  |  |  |  |  | XE404100 | 0 | 0 |  | 934 | 41 | 200 | 200 | C | UIO | X | E | XE40 | 4100 | E | 16 | X | EL | LND | 1610 |  |  | to be checked |  | 2011-04-12 | 2011-06-10 |  |  |  |  |  |  |  |  |  |  |
| XE504100 |  | CA41 Control Bldg - Cable Pulling SWGs intern |  | 60d | 2011-11-11 | 2012-01-26 | XE500C01, XE204100 SS+35d |  | -84d | 0d |  |  | Cable Pulling [2400 m]; Cable pulling [1200 h] | 48,000 | 1200,00 |  | XE504100 | 1200 | 0 |  | 934 | 41 | 200 | 200 | C | LND | X | E | XE50 | 4100 | E | 16 | X | EL | LND | 1610 | URMA |  |  |  | 2011-05-25 | 2011-08-03 | 2011-05-20 | 2012-02-10 | E-16-01-01 | m | 2500 | 2012-07-01 | 2011-10-01 | MTA |  |  |
| XE50410005 |  | CA41 Control Bldg - Testing / Commissioning 10kV SwGears |  | 40d | 2012-01-27 | 2012-03-15 | XE504100 |  | -84d | 0d |  |  |  |  |  |  | XE50410005 | 0 | 0 |  | 934 | 41 | 200 | 200 | C | LND | X | E | XE50 | 4100 | E | 16 | X | EL | LND | 1610 | URMA |  |  |  | 2011-08-04 | 2011-09-19 | 2011-05-20 | 2012-02-10 | E-16-01-01 |  |  | 2012-07-01 | 2011-10-01 |  |  |  |
| XE50410015 |  | CA41 Control Bldg - Energization CA41 / 10kV MV available | milestone | 0d | 2012-03-15 | 2012-03-15 | XE600C05, XE50410005 FF |  | -84d | 0d |  |  |  |  |  |  | XE50410015 | 0 | 0 |  | 934 | 41 | 200 | 200 | C | LND | X | E | XE50 | 4100 | E | 16 | X | EL | LND | 1610 | URMA |  |  |  | 2011-09-19 | 2011-09-19 | 2011-05-20 | 2012-02-10 | E-16-01-01 |  |  | 2012-07-01 | 2011-10-01 |  | 2012-02-15 |  |
| XE50410010 |  | CA41 Control Bldg - Cable Pulling to CA10/11/12/13/16/17/31 |  | 40d | 2012-06-09 | 2012-07-27 | XE401010, X020410055, X020410015, XE401201, XE504100 FF, XE505501 SS+10d, XE401301, XE401110, XE403110, XE401707, XE500C01 |  | -148.5d | 0d |  | TB26 - V - Construct-Winter partly * | Cable Pulling [11600 m]; Cable pulling [5800 h] | 232,000 | 5800,00 |  | XE50410010 | 5800 | 0 |  | 934 | 41 | 200 | 200 | C | LND | X | E | XE50 | 4100 | E | 16 | X | EL | LND | 1610 | URMA |  |  |  | 2011-08-02 | 2011-10-10 | 2011-05-20 | 2012-02-10 | E-16-01-01 | m | 12000 | 2012-07-01 | 2011-10-01 |  |  | x |
| XE604100 |  | CA41 Control Bldg - Cable Termination & Testing / LV Syst. CA16/31 |  | 40d | 2012-06-25 | 2012-08-10 | XE504100 SS+40d, XE504100 FF+12d, X0300005 SF+30d, XE50410015, XE50410010 FF+12d |  | -167.5d | 0d |  |  | Cable connecting [420 pcs]; Cable connecting [1050 h] | 42,000 | 1050,00 |  | XE604100 | 1050 | 0 |  | 934 | 41 | 200 | 200 | C | LND | X | E | XE60 | 4100 | E | 16 | X | ET | LND | 1610 | URMA |  |  |  |  |  |  |  |  |  |  |  |  |  |  |  |
| XJ604100 |  | CA41 Control Bldg - SAT System + Systeminterconnection to CA16 |  | 21d | 2012-07-25 | 2012-08-18 | XE604100 FS-14d |  | -87.5d | 20d |  |  |  |  | 1050,00 |  | XE604100 | 1050 | 0 |  | 934 | 41 | 200 | 200 | C | LND | X | J | XE60 | 4100 | J | 16 | X | ET | LND | 1610 | URMA |  |  |  |  |  |  |  |  |  |  |  |  |  |  |  |
|  | J | **Instrumentation** |  |  | 2011-10-12 | 2012-12-31 |  |  |  |  |  |  |  |  |  |  |  |  |  |  |  |  |  |  |  |  |  |  |  |  |  |  |  |  |  |  |  |  |  |  |  |  |  |  |  |  |  |  |  |  |  |  |
| XJ424100 |  | CA41 Control Bldg - Install Cable Trays by UI&O |  | 50d | 2011-10-12 | 2011-12-09 | XE204100 SS+10d, XE404100 FF |  | 64d | 22d |  |  | Secondary cable trays [360 m]; Install secondary cable trays [1350 h] | 54,000 | 1350,00 |  | XJ424100 | 1350 | 0 |  | 934 | 41 | 200 | 200 | C | LND | X | J | XJ42 | 4100 | J | 41 | X | IN | LND | 4100 |  |  |  |  | 2011-04-12 | 2011-06-10 |  |  |  | m | 550 |  |  |  |  |  |
| XJ304100 |  | CA41 Control Bldg - Install Field Devices - DELETED |  | 30d | 2011-11-05 | 2011-12-09 | XE204100 SS+30d |  | 80d | 141.5d |  |  | Field Instruments [153 pcs]; Install field instruments [842 h] | 33,660 | 842,00 |  | XJ304100 | 842 | 0 |  | 934 | 41 | 200 | 200 | C | LND | X | J | XJ30 | 4100 | J | 41 | X | IN | LND | 4100 |  |  |  |  |  |  |  |  |  |  |  |  |  |  |  |  |
| XJ544100 |  | CA41 Control Bldg - Pulling Singlecore / Multicore Cables |  | 50d | 2011-11-07 | 2012-02-28 | XE500C01, XE204100 SS+30d, XJ424100 FF+40d |  | 37d | 131.5d |  | TB26 - V - Construct-Winter partly * | Singlecore cables [8700 m]; Pull singlecore cables [6525 h] | 261,000 | 6525,00 |  | XJ544100 | 6525 | 0 |  | 934 | 41 | 200 | 200 | C | LND | X | J | XJ54 | 4100 | J | 41 | X | IN | LND | 4100 | URMA |  |  |  | 2011-05-31 | 2011-07-28 |  |  |  | m | 8375 |  |  |  |  |  |
| XJ804100 |  | CA41 Control Bldg - Inspections/ Mech. Acceptance/ Loop Checks |  | 125d | 2012-08-25 | 2012-12-31 | X3J120, XE50410010 FF+30d, XJ544100, XJ304100 FS+20d, X030410030, XJ604100 FS-14d |  | -125.5d | 0d |  | TB26 - 3 - Construction Normal 7days * CA17 | Loop Checks [400 pcs]; Loop checks [2000 h] | 80,000 | 2000,00 |  | XJ804100 | 2000 | 0 |  | 934 | 41 | 200 | 200 | C | LND | X | J | XJ80 | 4100 | J | 41 | X | LT | IMS | 4100 | URMA |  |  |  |  |  | 2011-06-10 | 2012-04-30 | E-17-02-01 |  |  | 2012-08-18 | 2012-03-01 |  | 2012-08-18 |  |

Notes:
- XW503140: P3 Activity Log Info: Clarification Surface Protection during Prefab
- X0104110: P3 Activity Log Info: Clarification Scope Control Building
- X0104100: P3 Activity Log Info: Clarification Scope Control Building
- XE204100: Current Status: 20110907 (O.Siegel): der Starttermin (30-Sep-2011) wurde von ET/IT-Abteilung / mitgeteilt / 04.01.2011 (O.Siegel): die genauen Angaben bzgl. des Starttermins stehen noch / aus

| ID | WBS | Activity | Type | Duration | Start | Finish | Predecessors | Complete | Remaining | Planned start | Planned finish | Total float | Free float | Constraint | Calendar | Resources | Cost | Actual cost | UDF_SAVE ACT ID | UDF_BUDGETED LABOR UNIT | UDF_ACTUAL LABOR UNIT | Department | Type of Work | Constr. Area | PMT-Area | PMT-Schedule Org | PMT-Phase | PMT-Respons. | WBS Phase | WBS Discipline | WBS Type of Work | WBS Objects | Russia WBS Discipline (Russia) | Russia Construction Area | Russia WBS Phase | IMS | UPT | Russia WBS Objects | Subcontractor | TB26 Ressource Budget | Inquiry/Order No | suspend date | resume date | UDF_SELECT UPDATE PROGRESS | UDF_CHECK RESOURCE DATES | Civil item | 4 week lookahead | Zeigen/n. Zeigen | UDF_Concrete | Comments | UDF_CHECK BASELINE | UDF_CONTRACT ITEM | TB26 Semantics | UDF_CONTRACT INDICATOR | UDF_COMMENTS | UDF_CHECK CRITICAL PATH |
| --- | --- | --- | --- | --- | --- | --- | --- | --- | --- | --- | --- | --- | --- | --- | --- | --- | --- | --- | --- | --- | --- | --- | --- | --- | --- | --- | --- | --- | --- | --- | --- | --- | --- | --- | --- | --- | --- | --- | --- | --- | --- | --- | --- | --- | --- | --- | --- | --- | --- | --- | --- | --- | --- | --- | --- | --- |
|  | 51 | **CA51 - Pipe Rack** |  |  | 2008-09-24 | 2012-08-15 |  |  |  |  |  |  |  |  |  |  |  |  |  |  |  |  |  |  |  |  |  |  |  |  |  |  |  |  |  |  |  |  |  |  |  |  |  |  |  |  |  |  |  |  |  |  |  |  |  |  |
| X0105100 |  | CA51 General - Mechanical Completion | milestone | 0d | 2012-08-15 | 2012-08-15 | XE505102, XE505103, XC605104, XE505104, XC605103, XE705103, P3R01S (other project), XV505101, XC605102, XE705102, XE915103, XC605101, XE915101, XE915104, XE505101, XE705101, XV505102, XJ525103, XV505103, XJ525101, XJ525104, X0105110, XE915102, XJ525102, XE705104, XV505104 |  |  |  |  | 9.5d | 136d |  | TB26 - 2 - Manuf and Delivy |  |  |  | X0105100 | 0 | 0 | 934 | XNK | 51 | 200 | 200 | C | LND | X | 0B | X010 | 5100 | 0 | 51 | X | MC | LND | 5100 |  |  |  |  |  |  |  |  |  |  |  |  |  |  |  |  |  |  |
| X0105110 |  | CA51 General - Construction Completion | milestone | 0d | 2012-08-15 | 2012-08-15 | XE505101, XE915101, XE915103, XE915104, XN605102, XN605103, XN205102l, XN405101, XN405102, XN405103, XN605104, XJ525101, XE505102, XE705102, XE805103, XJ525103, XE805101, XN205103u, XN405104, XJ325101, XE915102, XE705103, XJ525104, XN605101, XC195101, XC605101, XN205101u, XR40510410, XE705101, XJ525102, XE505103, XE705104, XC305101, XE805102, XN205104u, XE805104, XE505104 |  |  |  |  | -45.5d | 0d |  | TB26 - 2 - Manuf and Delivy |  |  |  | X0105110 | 0 | 0 | 934 | XNK | 51 | 200 | 200 | C | LND | X | 0B | X010 | 5100 | 0 | 51 | X | MC | LND | 5100 |  |  |  |  |  |  |  |  |  |  |  |  |  |  |  |  |  |  |
|  | 01 | **CA5101** |  |  | 2008-09-24 | 2012-07-27 |  |  |  |  |  |  |  |  |  |  |  |  |  |  |  |  |  |  |  |  |  |  |  |  |  |  |  |  |  |  |  |  |  |  |  |  |  |  |  |  |  |  |  |  |  |  |  |  |  |  |
|  | C | **Civil Work** |  |  | 2008-09-24 | 2011-10-10 |  |  |  |  |  |  |  |  |  |  |  |  |  |  |  |  |  |  |  |  |  |  |  |  |  |  |  |  |  |  |  |  |  |  |  |  |  |  |  |  |  |  |  |  |  |  |  |  |  |  |
| XC115101 |  | CA51 SR5101 - Excavation&Surface Prep by U/I/O |  | 294d | 2008-09-24 A | 2009-09-30 A | XC111100 SS | 100% |  |  |  |  |  |  |  |  |  |  | XC115101 | 0 | 0 | 934 |  | 51 | 200 | 200 | C | UIO | X | C | XC11 | 5101 | C | 51 | X | CW | LND | 5101 | MO11 |  |  |  |  |  |  |  |  |  |  |  |  |  |  |  |  |  |
| XC11510105 |  | CA51 SR5101 - Excavation |  | 26d | 2010-02-17 A | 2010-03-18 A | XC115101 | 100% |  |  |  |  |  |  |  | Excavation [4500 cbm]; Excavation [2250 h] | 180,000 | 180,000 | XC11510105 | 2250 | 2250 | 934 |  | 51 | 200 | 200 | C | MO02 | X | C | XC11 | 5101 | C | 10 | X | P | LND | 1010 | MO11 | 2250,00 | 999 |  |  |  |  |  |  |  |  |  |  |  |  |  |  |  |
| XC11510110 |  | CA51 SR5101 - SubBase (Gravel/Geogrid) for Concrete |  | 14d | 2010-03-22 A | 2010-04-07 A | XC11510105 | 100% |  | 2010-03-22 | 2010-04-06 |  |  |  |  | Sub Base for Concrete/Paving&Roads (Gravel) [400 cbm]; Subbase for Concrete [400 h] | 40,000 | 10,000 | XC11510110 | 400 | 400 | 934 |  | 51 | 200 | 200 | C | MO02 | X | C | XC11 | 5101 | C | 10 | X | P | LND | 1010 | MO11 | 400,00 | 999 |  |  |  |  |  |  |  |  |  |  |  |  |  |  |  |
| XC155101 |  | CA51 SR5101 - Piling |  | 7d | 2010-04-07 A | 2010-04-14 A | EC155101 (other project) FS+6d, XC11510110, F2910, XC11510105 FS+3d, XC115101 | 100% |  |  |  |  |  |  |  | Piles driven [87 pcs]; Piles driven [652.5 h] | 26,100 | 26,100 | XC155101 | 652,5 | 652,5 | 934 |  | 51 | 200 | 200 | C | MO02 | X | C | XC15 | 5101 | C | 51 | X | P | LND | 5101 | MO11 | 652,50 |  |  |  |  |  |  |  |  |  |  |  |  |  |  |  |  |
| XC205101 |  | CA51 SR5101 - Concrete Works |  | 20d | 2010-07-09 A | 2010-07-31 A | XC200C10 FS+5d, P3C02D1 (other project) FS+5d, XC155101, EC45510115 (other project), EC285101 (other project) FS+7d | 100% |  |  |  |  |  |  | TB26 - V - Construct-Winter partly * | Concrete works [220 cbm]; Concrete works [6600 h] | 3,418.28 |  | XC205101 | 6600 | 6600 | 934 |  | 51 | 200 | 200 | C | MO03 | X | C | XC20 | 5101 | C | 51 | X | mai | LND | 5101 | MO11 | 6600,00 |  |  |  |  |  |  |  |  |  |  |  |  |  |  |  |  |
| XC195101 |  | CA51 SR5101 - Backfill |  | 217d | 2010-09-20 A | 2011-09-16 | XC205101, XC915101 FS+10d |  | 18d |  |  | 132d | 0d |  | TB26 - T - Construct-Winter-3 (Dec/Jan/Feb free) * | Backfill & Compaction [2300 cbm]; Backfill & Compaction [3450 h] | 207,000 | 144,000 | XC195101 | 3450 | 2400 | 934 |  | 51 | 200 | 200 | C | CiC | X | C | XC19 | 5101 | C | 51 | X | mai | LND | 5101 | MO11 | 3450,00 |  | 2010-11-01 | 2010-12-01 | 27.8. | EF 13.6.13 |  |  |  |  |  |  |  |  |  |  |  |
| XC20510105 |  | CA51 SR5101 - Precast Concrete Elements |  | 25d | 2010-11-15 A | 2010-12-13 A | EC28510105 (other project), EC28510106 (other project), XCC02D2 FS+5d, P3C02D2 (other project) FS+15d | 100% |  |  |  |  |  |  |  |  |  |  | XC20510105 | 0 | 0 | 934 |  | 51 | 200 | 200 | C | MO04 | X | C | XC40 | 5101 | C | 51 | X | pre | LND | 5101 | MO11 |  |  |  |  |  |  |  |  |  |  |  |  |  |  |  |  |  |
| XC20510115 |  | CA51 SR5101 - Erection Precast Elements |  | 15d | 2011-02-01 A | 2011-02-17 A | XC20510105 FS+20d, XC205101 | 100% |  |  |  |  |  | start on or after 2011-02-01 |  | Precast Concrete Works [35 cbm]; Precast concrete works [87.5 h] | 3,500 | 3,500 | XC20510115 | 87,5 | 87,5 | 934 |  | 51 | 200 | 200 | C | MO04 | X | C | XC40 | 5101 | C | 51 | X | mai | LND | 5101 | MO11 | 87,50 |  |  |  |  |  | Comp | x |  |  |  |  |  |  |  |  |  |
| XC20510120 |  | CA51 SR5101 - Erection Precast Elements finished | milestone | 0d | 2011-02-17 A | 2011-02-17 A | XC20510115 FF-1d | 100% |  |  |  |  |  |  |  |  |  |  | XC20510120 | 0 | 0 | 934 |  | 51 | 200 | 200 | C | CiC | X | C | XC40 | 5101 | C | 31 | X | OB | LND | 3120 | MO11 |  |  |  |  |  |  |  | x | D |  |  |  |  |  |  |  |  |
| XC305101 |  | CA51 SR5101 - UG Installation (incl. Precast Manholes) |  | 25d | 2011-09-12 | 2011-10-10 | XC205101 FF+10d, EC305101 (other project) FS+10d, P3R02BS (other project), XC300C00, XC310C00, P3R02S1 (other project) FF, P3C02D4 (other project) FS+10d, P3R02AS1 (other project) FF, P3R02S1 (other project), ER445101 (other project), P3R02AS1 (other project) |  |  |  |  | 17d | 63d | start on or after 2011-09-12 | TB26 - V - Construct-Winter partly * |  |  |  | XC305101 | 0 | 0 | 934 |  | 51 | 200 | 200 | C | CiC | X | C | XC30 | 5101 | C | 51 | X | mai | LND | 5101 |  |  |  |  |  | 27.8. |  |  |  |  | 1 |  |  |  |  |  |  |  |
| XC605101 |  | CA51 SR5101 - Paving |  | 20d | 2011-09-17 | 2011-10-10 | XC195101, XN205101l |  |  |  |  | 132d | 35d |  | TB26 - T - Construct-Winter-3 (Dec/Jan/Feb free) * | Gravel [320 sqm]; Gravel [16 h] | 1,182.54 |  | XC605101 | 16 | 0 | 934 |  | 51 | 200 | 200 | C | CiC | X | C | XC60 | 5101 | C | 51 | X | PV | LND | 5101 | MO11 | 16,00 |  |  |  |  |  |  |  |  | 1 |  |  |  |  |  |  |  |
|  | N | **Structural Steel** |  |  | 2011-02-21 | 2011-09-10 |  |  |  |  |  |  |  |  |  |  |  |  |  |  |  |  |  |  |  |  |  |  |  |  |  |  |  |  |  |  |  |  |  |  |  |  |  |  |  |  |  |  |  |  |  |  |  |  |  |  |
| XN705101 |  | CA51 SR5101 - KMD Assy Drawings | milestone | 0d | 2011-02-21 A | 2011-02-21 A |  | 100% |  |  |  |  |  | finish on 2011-02-21 |  |  |  |  | XN705101 | 0 | 0 | 934 | XNK | 51 | 200 | 200 | C | LND | X | N | XN05 | 5101 | N | 51 | X | PR | LND | 5101 |  | 22t |  |  |  |  |  |  |  | KMD |  | to be confirmed | x |  |  |  |  |  |
| XN715101 |  | CA51 SR5101 - Steel Deliveries | milestone | 0d | 2011-02-25 A | 2011-02-25 A |  | 100% |  |  |  |  |  | finish on 2011-02-25 | TB26 - 3 - Construction Normal 7days * CA17 |  |  |  | XN715101 | 0 | 0 | 934 | XNK | 51 | 200 | 200 | C | LND | X | N | XN06 | 5101 | N | 51 | X | PR | LND | 5101 |  | 22t |  |  |  |  |  |  |  | SD |  | to be confirmed |  |  |  |  |  |  |
| XN205101l |  | CA51 SR5101 - Installation Steel Structure (lower part) |  | 59d | 2011-04-09 A | 2011-06-21 A | XR40510105, P3N01AN (other project), EN685101 (other project), XN715101 FS+10d, XR400C00, XN705101, P3N012D (other project) FS+10d | 100% |  | 2011-04-09 | 2011-06-20 |  |  |  | TB26 - V - Construct-Winter partly * | Piperacks, Main structures [2040 h]; Piperacks, Main Structures [48 t] | 81,600 | 80,060.38 | XN205101l | 2040 | 2040 | 934 | XNK | 51 | 200 | 200 | C | LND | X | N | XN20 | 5101 | N | 51 | X | PR | LND | 5101 | ChSK | 2040,00 |  |  |  |  |  |  | x |  |  |  |  | E-04-22 | t |  |  |  |
| XN205101u |  | CA51 SR5101 - Installation Steel Structure (upper part) |  | 106d | 2011-05-10 A | 2011-09-10 | XN715101 FS+10d, XN255101, XN705101 |  | 13d |  |  | 183d | 0d |  | TB26 - V - Construct-Winter partly * | Piperacks, Main structures [2040 h]; Piperacks, Main Structures [48 t] | 81,600 | 28,900 | XN205101u | 2040 | 637,5 | 934 | XNK | 51 | 200 | 200 | C | LND | X | N | XN20 | 5101 | N | 51 | X | PR | LND | 5101 | ChSK | 2040,00 |  |  |  | 27.8. | actual finish |  |  |  |  |  |  | E-04-22 | t | UDF_G4 |  |  |
| XN255101 |  | CA51 SR5101 - Installation fireproof castables |  | 6d | 2011-06-27 A | 2011-07-02 A | XN205101l | 100% |  |  |  |  |  | start on or after 2011-06-27 | TB26 - V - Construct-Winter partly * |  |  |  | XN255101 | 0 | 0 | 934 | XNK | 51 | 200 | 200 | C | LND | X | N | XN20 | 5101 | N | 51 | X | PR | LND | 5101 | MO11 | 95 |  |  |  |  |  |  |  |  |  |  |  | E-04-22 | t |  | action by MO11 |  |
| XN405101 |  | CA51 SR5101 - Install Railings,Ladders,etc. |  | 24d | 2011-08-15 A | 2011-09-10 | XN205101u, XN205101l |  | 13d |  |  | 240d | 278.5d |  |  | Ladders & platforms [8 t]; Ladders & platforms [800 h] | 362.15 |  | XN405101 | 800 | 0 | 934 | XNK | 51 | 200 | 200 | C | LND | X | N | XN40 | 5101 | N | 51 | X | SS | LND | 5101 | ChSK | 800,00 |  |  |  | 27.8. | x |  |  |  |  |  | x |  |  | UDF_G4 |  | Check Roof - Cladding |
| XN605101 |  | CA51 SR5101 - Install Gratings |  | 24d | 2011-08-15 A | 2011-09-10 | XN205101u, XN205101l FS+10d |  | 13d |  |  | 240d | 278.5d |  |  | Grating [640 sqm]; Grating [2400 h] | 1,241.67 |  | XN605101 | 2400 | 0 | 934 | XNK | 51 | 200 | 200 | C | LND | X | N | XN60 | 5101 | N | 51 | X | SS | LND | 5101 | ChSK | 2400,00 |  |  |  | 27.8. | x |  |  |  |  |  | x |  |  | UDF_G4 |  | Check Roof - Cladding |

Notes:
- XC115101: P3 Activity Log Info: incl. Dewatering/Drainage
- XC155101: P3 Activity Log Info: 130 driven piles expected,20/d/machine
- XC20510115: Current Status: 07.02.2011 (O. Siegel): zum 01.02.2011 wurden keine Arbeiten durchgefьhrt / (Angaben aus CPMR). Startdatum auf den 02.02.2011 verschoben. / 13.01.2011 (Oxana): zum 01.01.2011 wurden keine Arbeiten durchgefьhrt / (Angaben aus CPMR). Startdatum auf den 14.01.2011 verschoben. Endtermin wird / gehalten (Angaben von Mostostroy).
- XC305101: P3 Activity Log Info: Clarification Prefab / Catch Basins/pulling pits / Current Status: 12.0.2011 (O. Siegel): nach Rьcksprache mit MO11 am 11 und / 12.Januar 11, wurde der 25-April-11 als Starttermin besprochen.
- XN715101: Scope: 09.02.2011: weight: 110 ton / Current Status: 19.02.2011 (O.Siegel): bis heute wurden 12 tonnen fьr den / lower part und 29 tonnen fьr den upper part ausgeliefert.
- XN205101l: Scope: 16.02.2011 (O.Siegel): die Liefermenge von 110 t / (Angaben vom 09.02.2011) wurden gleich aufgeteilt auf lower und upper part.
- XN205101u: Scope: 16.02.2011 (O.Siegel): die Liefermenge von 110 t / (Angaben vom 09.02.2011) wurden gleich aufgeteilt auf lower und upper part.

| ID | WBS | Activity | Duration | Start | Finish | Predecessors | Complete | Remaining | Planned start | Planned finish | Total float | Free float | Calendar | Resources | Cost | Actual cost | TB26 Ressource Budget | UDF_CONTRACT INDICATOR | UDF_CHECK CRITICAL PATH | UDF_SELECT UPDATE PROGRESS | UDF_SAVE ACT ID | UDF_BUDGETED LABOR UNIT | UDF_ACTUAL LABOR UNIT | UDF_CHECK RESOURCE DATES | UDF_COMMENTS_0827 | Department | Constr. Area | PMT-Area | PMT-Schedule Org | PMT-Phase | PMT-Respons. | WBS Phase | WBS Discipline | WBS Type of Work | WBS Objects | Russia WBS Discipline (Russia) | Russia Construction Area | Russia WBS Phase | IMS | UPT | Russia WBS Objects | 4 week lookahead | Subcontractor | UDF_CONTRACT START DATE | UDF_CONTRACT FINISH DATE | UDF_CONTRACT ITEM | UDF_PLANNED START | UDF_PLANNED FINISH | TB26 Semantics | TB26 Material Res Values | UDF_ELECTRICAL START | UDF_ELECTRICAL FINISH | UDF_CONTRACT FINISH DATE REV1 | UDF_CONTRACT START DATE REV1 | UDF_CHECK BASELINE | UDF_INDICATOR | UDF_Vendor Representatives | UDF_CONTRACT FINISH DATE REV2 | UDF_CONTRACT START DATE REV2 |
| --- | --- | --- | --- | --- | --- | --- | --- | --- | --- | --- | --- | --- | --- | --- | --- | --- | --- | --- | --- | --- | --- | --- | --- | --- | --- | --- | --- | --- | --- | --- | --- | --- | --- | --- | --- | --- | --- | --- | --- | --- | --- | --- | --- | --- | --- | --- | --- | --- | --- | --- | --- | --- | --- | --- | --- | --- | --- | --- | --- |
|  | H | **HVAC** |  |  |  |  |  |  |  |  |  |  |  |  |  |  |  |  |  |  |  |  |  |  |  |  |  |  |  |  |  |  |  |  |  |  |  |  |  |  |  |  |  |  |  |  |  |  |  |  |  |  |  |  |  |  |  |  |  |
|  | U | **Package Units** |  |  |  |  |  |  |  |  |  |  |  |  |  |  |  |  |  |  |  |  |  |  |  |  |  |  |  |  |  |  |  |  |  |  |  |  |  |  |  |  |  |  |  |  |  |  |  |  |  |  |  |  |  |  |  |  |  |
|  | B | **Mechanical - Stationary Equipment** |  |  |  |  |  |  |  |  |  |  |  |  |  |  |  |  |  |  |  |  |  |  |  |  |  |  |  |  |  |  |  |  |  |  |  |  |  |  |  |  |  |  |  |  |  |  |  |  |  |  |  |  |  |  |  |  |  |
|  | M | **Mechanical - Rotating Equipment** |  |  |  |  |  |  |  |  |  |  |  |  |  |  |  |  |  |  |  |  |  |  |  |  |  |  |  |  |  |  |  |  |  |  |  |  |  |  |  |  |  |  |  |  |  |  |  |  |  |  |  |  |  |  |  |  |  |
|  | R | **Piping** |  | 2011-02-07 | 2012-03-06 |  |  |  |  |  |  |  |  |  |  |  |  |  |  |  |  |  |  |  |  |  |  |  |  |  |  |  |  |  |  |  |  |  |  |  |  |  |  |  |  |  |  |  |  |  |  |  |  |  |  |  |  |  |  |
| XR205101 |  | CA51 SR5101 - Piping Prefabrication (Start w. Cooling Water Line) | 181d | 2011-02-07 A | 2011-09-10 | XR200C00 SS, P3R06BS1 (other project), P3R06S1 (other project) FF+20d, ER495101 (other project) SS, A1KL0020 (other project) FF+10d, P3R06DS1 (other project) FF+20d | 100% | 13d |  |  | 150d | 471.5d |  | A/G piping prefabrication [1590 Fpi]; A/G Piping (Prefab) [5962.5 h] | 5,594.9 |  | 5962,50 | UDF_G4 | Prefabrication | 27.8. | XR205101 | 5962,5 | 2921,25 | actual finish | Expected Finish 10.09.11 | 934 | 51 | 200 | 200 | C | LND | X | R | XR20 | 5101 | R | 51 | X | PRP | LND | 5101 | x | VNZM |  |  |  |  |  |  |  |  |  |  |  |  |  |  |  |  |
| XR40510205 |  | CA51 SR5102 - Piping Install prior Steel Struc (Cooling Water) | 85d | 2011-03-14 A | 2011-06-23 A | XC20510220 FF+5d, XR200C10, XR205102 SS+25d, ER475102 (other project) FS-20d | 100% |  | 2011-03-14 | 2011-06-25 |  |  | TB26 - V - Construct-Winter partly * | A/G piping field installation [150 Fpi]; A/G Piping (Field) [937.5 h] | 5,912.7 |  | 937,50 |  |  | x | XR40510205 | 937,5 | 937,5 |  |  | 934 | 51 | 200 | 200 | C | LND | X | R | XR40 | 5102 | R | 51 | X | PI | LND | 5102 |  | VNZM | 2010-12-20 | 2011-07-30 | E-06-03-09 | 2011-02-05 |  |  |  |  |  |  |  |  |  |  |  |  |
| XR40510405 |  | CA51 SR5104 - Piping Install prior Steel Struc | 77d | 2011-03-24 A | 2011-06-23 A | XR205104 SS+5d, XR40510305 SS+10d, XC20510420 FF+10d, ER475104 (other project) FS-20d, F4870 FF+10d | 100% |  | 2011-03-24 | 2011-06-25 |  |  | TB26 - V - Construct-Winter partly * | A/G piping field installation [150 Fpi]; A/G Piping (Field) [937.5 h] | 5,912.7 |  | 937,50 |  |  |  | XR40510405 | 937,5 | 937,5 |  |  | 934 | 51 | 200 | 200 | C | LND | X | R | XR40 | 5104 | R | 51 | X | PI | LND | 5104 |  | VNZM | 2010-12-20 | 2011-07-30 | E-06-03-09 | 2011-02-05 |  |  |  |  |  |  |  |  |  |  |  |  |
| XR40510105 |  | CA51 SR5101 - Piping Install prior Steel Struc (Cooling Water) | 75d | 2011-03-28 A | 2011-06-23 A | XC20510120 FF+5d, XR205101 SS+25d, XR200C10, ER475101 (other project) FS-20d | 100% |  | 2011-03-28 | 2011-06-25 |  |  |  | A/G piping field installation [150 Fpi]; A/G Piping (Field) [937.5 h] | 5,912.7 |  | 937,50 |  |  |  | XR40510105 | 937,5 | 937,5 |  |  | 934 | 51 | 200 | 200 | C | LND | X | R | XR40 | 5101 | R | 51 | X | PI | LND | 5101 | x | VNZM | 2010-12-20 | 2011-07-30 | E-06-03-09 | 2011-02-05 |  |  |  |  |  |  |  |  |  |  |  |  |
| XR40510305 |  | CA51 SR5103 - Piping Install prior Steel Struc (Cooling Water) | 75d | 2011-03-28 A | 2011-06-23 A | XR40510205 SS+10d, ER475103 (other project) FS-20d, XR205103 SS+4d, XC20510320 FF+10d | 100% |  | 2011-03-28 | 2011-06-25 |  |  | TB26 - V - Construct-Winter partly * | A/G piping field installation [150 Fpi]; A/G Piping (Field) [937.5 h] | 5,912.7 |  | 937,50 |  |  |  | XR40510305 | 937,5 | 937,5 |  |  | 934 | 51 | 200 | 200 | C | LND | X | R | XR40 | 5103 | R | 51 | X | PI | LND | 5103 |  | VNZM | 2010-12-20 | 2011-07-30 | E-06-03-09 | 2011-02-05 |  |  |  |  |  |  |  |  |  |  |  |  |
| XR40510110 |  | CA51 SR5101 - Piping Install after Steel Struc | 84d | 2011-06-25 A | 2011-09-30 | IMS-C-000190 FF, XN205101u FS+5d |  | 30d |  |  | -29d | 0d |  | A/G piping field installation [1800 Fpi]; Control & Shut-off valves [5 pcs]; A/G Piping (Field) [11250 h]; Install Control & Shut-off Valves [26.25 h] | 15,033.54 | 350 | 11276,25 | UDF_G4 |  | 27.8. | XR40510110 | 11276,25 | 4869 | x | Expected Finish 30.09.11 | 934 | 51 | 200 | 200 | C | LND | X | R | XR40 | 5101 | R | 51 | X | PI | LND | 5101 |  | VNZM |  |  | E-06-03-09 |  |  |  |  |  |  |  |  |  |  |  |  |  |
| XR605101 |  | CA51 SR5101 - Piping Pressure Tests | 40d | 2011-09-29 | 2011-11-15 | XR600C00 SS, X0300020, X0300025, XR40510110 FF+38d |  |  |  |  | -29d | 0d |  |  |  |  | 382 |  |  |  | XR605101 | 0 | 0 |  |  | 934 | 51 | 200 | 200 | C | LND | X | R | XR60 | 5101 | R | 51 | X | HY | LND | 5101 |  | VNZM |  |  | E-06-03-09 |  |  |  |  |  |  |  |  |  |  |  |  |  |
| XR605102 |  | CA51 SR5102 - Piping Pressure Tests | 40d | 2011-09-29 | 2011-11-21 | XR600C00 SS, XR40510210 FF+28d, X0300020, XR605101 SS |  |  |  |  | -29d | 0d | TB26 - T - Construct-Winter-3 (Dec/Jan/Feb free) * |  |  |  | 382 |  |  |  | XR605102 | 0 | 0 |  |  | 934 | 51 | 200 | 200 | C | LND | X | R | XR60 | 5102 | R | 51 | X | HY | LND | 5102 |  | VNZM |  |  | E-06-03-09 |  |  |  |  |  |  |  |  |  |  |  |  |  |
| XR605103 |  | CA51 SR5103 - Piping Pressure Tests | 40d | 2011-09-29 | 2011-11-21 | XR605101 SS, XR40510310 FF+20d, XR600C00 SS, X0300020 |  |  |  |  | -29d | 0d | TB26 - T - Construct-Winter-3 (Dec/Jan/Feb free) * |  |  |  | 382 |  |  |  | XR605103 | 0 | 0 |  |  | 934 | 51 | 200 | 200 | C | LND | X | R | XR60 | 5103 | R | 51 | X | HY | LND | 5103 |  | VNZM |  |  | E-06-03-09 |  |  |  |  |  |  |  |  |  |  |  |  |  |
| XR605104 |  | CA51 SR5104 - Piping Pressure Tests | 40d | 2011-09-29 | 2011-11-21 | XR605101 SS, X0300020, XR40510410 FF+20d |  |  |  |  | 2d | 0d | TB26 - T - Construct-Winter-3 (Dec/Jan/Feb free) * |  |  |  | 382 |  |  |  | XR605104 | 0 | 0 |  |  | 934 | 51 | 200 | 200 | C | LND | X | R | XR60 | 5104 | R | 51 | X | HY | LND | 5104 |  | VNZM |  |  | E-06-03-09 |  |  |  |  |  |  |  |  |  |  |  |  |  |
| XR805101 |  | CA51 SR5101 - Piping Reinstatement | 30d | 2011-10-22 | 2011-11-26 | IMS-C-000360 FF, XR605101 FF+10d |  |  |  |  | 122d | 0d |  |  |  |  | 191 |  |  |  | XR805101 | 0 | 0 |  |  | 934 | 51 | 200 | 200 | C | LND | X | R | XR80 | 5101 | R | 51 | X | PI | LND | 5101 |  | VNZM |  | 2011-07-30 | E-06-03-09 |  | 2011-09-09 |  |  |  |  |  |  |  |  |  |  |  |
| XR805103 |  | CA51 SR5103 - Piping Reinstatement | 35d | 2011-12-14 | 2012-03-06 | IMS-C-000360 FF, XR605103 FF+10d |  |  |  |  | 305.5d | 0d | TB26 - V - Construct-Winter partly * |  |  |  | 191 |  |  |  | XR805103 | 0 | 0 |  |  | 934 | 51 | 200 | 200 | C | LND | X | R | XR80 | 5103 | R | 51 | X | PI | LND | 5103 |  | VNZM |  | 2011-07-30 | E-06-03-09 |  | 2011-09-09 |  |  |  |  |  |  |  |  |  |  |  |
| XR805104 |  | CA51 SR5104 - Piping Reinstatement | 35d | 2011-12-14 | 2012-03-06 | IMS-C-000360 FF, XR605104 FF+10d |  |  |  |  | 305.5d | 0d | TB26 - V - Construct-Winter partly * |  |  |  | 191 |  |  |  | XR805104 | 0 | 0 |  |  | 934 | 51 | 200 | 200 | C | LND | X | R | XR80 | 5104 | R | 51 | X | PI | LND | 5104 |  | VNZM |  | 2011-07-30 | E-06-03-09 |  | 2011-09-09 |  |  |  |  |  |  |  |  |  |  |  |
| XR805102 |  | CA51 SR5102 - Piping Reinstatement | 32d | 2011-12-21 | 2012-03-06 | XR605102 FF+10d, IMS-C-000360 FF |  |  |  |  | 53d | 0d | TB26 - V - Construct-Winter partly * |  |  |  | 191 |  |  |  | XR805102 | 0 | 0 |  |  | 934 | 51 | 200 | 200 | C | LND | X | R | XR80 | 5102 | R | 51 | X | PI | LND | 5102 |  | VNZM |  | 2011-07-30 | E-06-03-09 |  | 2011-09-09 |  |  |  |  |  |  |  |  |  |  |  |
|  | E | **Electrical** |  | 2010-07-07 | 2012-07-27 |  |  |  |  |  |  |  |  |  |  |  |  |  |  |  |  |  |  |  |  |  |  |  |  |  |  |  |  |  |  |  |  |  |  |  |  |  |  |  |  |  |  |  |  |  |  |  |  |  |  |  |  |  |  |
| XC915101 |  | CA51 SR5101 - Installation Earthing Foundations_CIVIL | 26d | 2010-07-07 A | 2010-08-05 A | EE905101 (other project), XC205101 SS | 100% |  |  |  |  |  |  | Grounding & Lightning [150 pcs]; Grounding & Lightning [1687.5 h] | 67,500 | 67,500 | 1687,50 |  |  |  | XC915101 | 1687,5 | 1687,5 |  |  | 934 | 51 | 200 | 200 | C | LND | X | C | XE91 | 5101 | C | 51 | X | EA | LND | 5101 |  | MO11 | 2011-03-10 | 2011-09-20 | E-16-07-15 |  |  |  |  |  |  |  |  |  |  |  |  |  |
| XE405101 |  | CA51 SR5101 - Install Cable Trays | 9d | 2011-08-24 A | 2011-09-07 | P3E16S (other project), EE46510110 (other project), E3E1635 (other project), EE46510120 (other project) FF, XN205101u |  | 10d | 2011-08-24 | 2011-09-02 | -7d | 3d | TB26 - V - Construct-Winter partly * | Cable trays/conduits [1430 m]; Cable trays [4290 h] | 171,600 | 12,870 | 4290,00 |  |  | 27.8. | XE405101 | 4290 | 0 | x |  | 934 | 51 | 200 | 200 | C | LND | X | E | XE40 | 5101 | E | 51 | X | EL | LND | 5101 |  | URMA | 2011-03-10 | 2011-05-31 | E-15-01-01 |  |  | m | 1900 | 2011-05-04 | 2011-06-21 | 2011-09-15 | 2011-05-23 | x | UDF_G2 |  |  |  |
| XE915101 |  | CA51 SR5101 - Installation Earthing Foundations_E/I | 10d | 2011-09-12 | 2011-09-22 | XN205101u, XJ425101, XE405101 |  |  |  |  | 230d | 268.5d |  |  |  |  | 170 |  |  |  | XE915101 | 0 | 0 |  |  | 934 | 51 | 200 | 200 | C | LND | X | E | XE91 | 5101 | E | 51 | X | EA | LND | 5101 |  | URMA | 2011-03-10 | 2011-09-20 | E-16-07-15 |  |  |  |  |  |  | 2012-02-15 | 2011-05-23 |  | UDF_G2 |  |  |  |
| XE805101 |  | CA51 SR5101 - Install Heat Tracing | 50d | 2011-11-03 | 2012-02-27 | XE800C00 SS, E3E1950 (other project), XR605101 FS-10d, XW505101 FF+20d, P3E19S (other project) |  |  |  |  | 85d | 32d | TB26 - V - Construct-Winter partly * | Electrical Heat Tracing [2600 m]; Electrical heat tracing [1300 h] | 52,000 |  | 1300,00 |  |  |  | XE805101 | 1300 | 0 |  |  | 934 | 51 | 200 | 200 | C | LND | X | E | XE80 | 5101 | E | 51 | X | HT | LND | 5101 |  | URMA | 2011-06-20 | 2012-03-20 | E-16-04-01 |  |  |  |  |  |  | 2012-06-30 | 2011-09-15 |  | UDF_G2 | 005 | 2012-02-15 | 2011-05-23 |
| XE705101 |  | CA51 SR5101 - Install Lighting & Small Power | 40d | 2011-11-08 | 2012-02-07 | EE765101 (other project), E3E0935 (other project), XP341610 FS+50d, XE405101, P3E09S (other project), P3E03S2 (other project) FF+20d, EE76510110 (other project) |  |  |  |  | 106d | 8d | TB26 - V - Construct-Winter partly * | Cable Pulling [600 m]; Lighting illuminates [110 pcs]; Lighting (iluminates) [1100 h]; Cable pulling [300 h] | 56,000 |  | 1400,00 |  |  |  | XE705101 | 1400 | 0 |  |  | 934 | 51 | 200 | 200 | C | LND | X | E | XE70 | 5101 | E | 51 | X | EL | LND | 5101 |  | URMA | 2011-05-10 | 2012-01-31 | E-16-03-01 |  |  |  |  |  |  | 2012-05-10 | 2011-08-15 |  | UDF_G2 |  |  |  |
| XE505101 |  | CA51 SR5101 - Cable Pulling Electric | 60d | 2012-05-17 | 2012-07-27 | XE405101, XE505402 SS, P3E15BS (other project), EE565101 (other project), P3E15CS (other project), XE500C01, P3E15AS (other project) |  |  |  |  | -55.5d | 0d | TB26 - V - Construct-Winter partly * | Cable Pulling [16900 m]; Cable pulling [8450 h] | 338,000 |  | 8450,00 |  |  |  | XE505101 | 8450 | 0 |  |  | 934 | 51 | 200 | 200 | C | LND | X | E | XE50 | 5101 | E | 51 | X | EL | LND | 5101 |  | URMA | 2011-05-20 | 2012-02-10 | E-16-01-01 |  |  | m | 17500 | 2011-08-02 | 2011-10-10 | 2012-07-01 | 2011-10-01 |  | UDF_G2 |  |  |  |

Notes:
- XR40510205: Current Status: 19.02.2011 (O.Siegel): am 12.02.2011 erfolgte eine / Einladung an VNZM zur Ьbergabe des Gewerks von MO11 an VNZM. VNZM ist zum / vereinbarten Termin nicht erschienen.
- XR40510405: Current Status: 19.02.2011 (O.Siegel): am 12.02.2011 erfolgte eine / Einladung an VNZM zur Ьbergabe des Gewerks von MO11 an VNZM. VNZM ist zum / vereinbarten Termin nicht erschienen.
- XR40510105: Current Status: 19.02.2011 (O.Siegel): am 12.02.2011 erfolgte eine / Einladung an VNZM zur Ьbergabe des Gewerks von MO11 an VNZM. VNZM ist zum / vereinbarten Termin nicht erschienen.
- XR40510305: Current Status: 19.02.2011 (O.Siegel): am 12.02.2011 erfolgte eine / Einladung an VNZM zur Ьbergabe des Gewerks von MO11 an VNZM. VNZM ist zum / vereinbarten Termin nicht erschienen.
- XE405101: UDF_PREDECESSOR: XN30, Piping 50%
- XE915101: UDF_PREDECESSOR: XN30, DEL XE40, DEL XE80, DEL XJ40, Civil 100%, Equipment 100%
- XE805101: UDF_PREDECESSOR: XR40, Piping 50% pressure tests
- XE705101: UDF_PREDECESSOR: XE40, Civil 100%
- XE505101: UDF_PREDECESSOR: XE40, XE50, DEL XE34

| ID | WBS | Activity | Type | Duration | Start | Finish | Predecessors | Complete | Remaining | Planned start | Planned finish | Total float | Free float | Constraint | Calendar | Resources | Cost | Actual cost | TB26 Ressource Budget | UDF_CONTRACT START DATE | UDF_CONTRACT FINISH DATE | UDF_CONTRACT ITEM | TB26 Semantics | TB26 Material Res Values | UDF_ELECTRICAL START | UDF_ELECTRICAL FINISH | UDF_CONTRACT FINISH DATE REV1 | UDF_CONTRACT START DATE REV1 | UDF_SAVE ACT ID | UDF_BUDGETED LABOR UNIT | UDF_ACTUAL LABOR UNIT | UDF_PREDECESSOR | UDF_INDICATOR | Department | Constr. Area | PMT-Area | PMT-Schedule Org | PMT-Phase | PMT-Respons. | WBS Phase | WBS Discipline | WBS Type of Work | WBS Objects | Russia WBS Discipline (Russia) | Russia Construction Area | Russia WBS Phase | IMS | UPT | Russia WBS Objects | Subcontractor | UDF_PENALIZED FINISH | UDF_COMMENTS_0827 | Inquiry/Order No | suspend date | resume date | UDF_SELECT UPDATE PROGRESS | UDF_CHECK RESOURCE DATES | Civil item | 4 week lookahead | Zeigen/n. Zeigen | UDF_Concrete | Comments | UDF_CHECK BASELINE | Type of Work | UDF_CONTRACT INDICATOR | UDF_COMMENTS | UDF_CHECK CRITICAL PATH |
| --- | --- | --- | --- | --- | --- | --- | --- | --- | --- | --- | --- | --- | --- | --- | --- | --- | --- | --- | --- | --- | --- | --- | --- | --- | --- | --- | --- | --- | --- | --- | --- | --- | --- | --- | --- | --- | --- | --- | --- | --- | --- | --- | --- | --- | --- | --- | --- | --- | --- | --- | --- | --- | --- | --- | --- | --- | --- | --- | --- | --- | --- | --- | --- | --- | --- | --- | --- |
|  | J | **Instrumentation** |  |  | 2011-08-15 | 2012-07-16 |  |  |  |  |  |  |  |  |  |  |  |  |  |  |  |  |  |  |  |  |  |  |  |  |  |  |  |  |  |  |  |  |  |  |  |  |  |  |  |  |  |  |  |  |  |  |  |  |  |  |  |  |  |  |  |  |  |  |  |  |  |
| XJ425101 |  | CA51 SR5101 - Install CableTrays Instrumentation |  | 20d | 2011-08-15 A | 2011-09-07 | XE405101, EJ46510110 (other project), XN205101u |  | 10d | 2011-10-05 | 2011-10-27 | 93d | 3d |  | TB26 - V - Construct-Winter partly * | Main cable trays [600 m]; Install Main Cable trays [1800 h] | 72,000 |  | 1800,00 | 2011-03-10 | 2011-05-31 | E-15-01-01 | m | 1700 | 2011-04-21 | 2011-06-21 | 2011-09-15 | 2011-05-23 | XJ425101 | 1800 | 0 | XE40, XJ32, Equipment 100%, Piping 50% | UDF_G2 | 934 | 51 | 200 | 200 | C | LND | X | J | XJ42 | 5101 | J | 51 | X | IN | LND | 5101 | URMA |  |  |  |  |  |  |  |  |  |  |  |  |  |  |  |  |  |
| XJ325101 |  | CA51 SR5101 - Install Junction Boxes |  | 15d | 2011-09-27 | 2011-10-13 | P3J06FS (other project) FF, P3J06ES (other project) FS+14d, EJ32171005 (other project), XE405101 FS-10d |  |  |  |  | 62d | 127.5d |  | TB26 - V - Construct-Winter partly * | Junction Boxes/Cabinets/Panels [38 pcs]; Install Junction Boxes/ Cabinets/ Panels [950 h] | 38,000 |  | 950,00 | 2011-03-10 | 2011-09-20 | E-17-04-15 |  |  |  |  | 2012-03-15 | 2011-08-10 | XJ325101 | 950 | 0 | Civil 100%, Equipment 100%, Piping 50% | UDF_G2 | 934 | 51 | 200 | 200 | C | LND | X | J | XJ32 | 5101 | J | 51 | X | IN | LND | 5101 | URMA | 2012-03-15 | to be checked / Battery limit only ?? |  |  |  |  |  |  |  |  |  |  |  |  |  |  |  |
| XJ525101 |  | CA51 SR5101 - Pulling Instrument Cables |  | 50d | 2012-05-17 | 2012-07-16 | XJ525401 SS, P3J17S (other project), XJ325101, P3J17S1 (other project), XJ425101, XE500C01, XE405101 |  |  |  |  | -65.5d | 0d |  | TB26 - V - Construct-Winter partly * | Multicore cables [4800 m]; Pull multicore cables [2400 h] | 96,000 |  | 2400,00 | 2011-03-10 | 2011-09-20 | E-17-04-15 | m | 3500 | 2011-08-13 | 2011-10-10 | 2012-03-15 | 2011-08-10 | XJ525101 | 2400 | 0 | XE40, XJ32, XJ52 | UDF_G2 | 934 | 51 | 200 | 200 | C | LND | X | J | XJ52 | 5101 | J | 51 | X | IN | LND | 5101 | URMA | 2012-03-15 |  |  |  |  |  |  |  |  |  |  |  |  |  |  |  |  |
|  | S | **Safety & Environment** |  |  |  |  |  |  |  |  |  |  |  |  |  |  |  |  |  |  |  |  |  |  |  |  |  |  |  |  |  |  |  |  |  |  |  |  |  |  |  |  |  |  |  |  |  |  |  |  |  |  |  |  |  |  |  |  |  |  |  |  |  |  |  |  |  |
|  | W | **Painting** |  |  | 2011-09-29 | 2011-12-20 |  |  |  |  |  |  |  |  |  |  |  |  |  |  |  |  |  |  |  |  |  |  |  |  |  |  |  |  |  |  |  |  |  |  |  |  |  |  |  |  |  |  |  |  |  |  |  |  |  |  |  |  |  |  |  |  |  |  |  |  |  |
| XW505101 |  | CA51 SR5101 - Surf.Protection Piping |  | 70d | 2011-09-29 | 2011-12-20 | XR805101 FF+20d, XR205101 SS+20d |  |  |  |  | 122d | 32d |  |  | Piping painting [482 sqm]; Piping painting [1205 h] | 1,413.14 |  | 1205,00 |  |  |  |  |  |  |  |  |  | XW505101 | 1205 | 0 |  |  | 934 | 51 | 200 | 200 | C | LND | X | W | XW50 | 5101 | W | 51 | X | PA | LND | 5101 | VNZM |  |  |  |  |  |  |  |  |  |  |  |  |  |  |  |  |  |
|  | V | **Insulation** |  |  | 2012-03-01 | 2012-06-23 |  |  |  |  |  |  |  |  |  |  |  |  |  |  |  |  |  |  |  |  |  |  |  |  |  |  |  |  |  |  |  |  |  |  |  |  |  |  |  |  |  |  |  |  |  |  |  |  |  |  |  |  |  |  |  |  |  |  |  |  |  |
| XV505101 |  | CA51 SR5101 - Insulation Piping |  | 90d | 2012-03-01 | 2012-06-23 | XE805101 SS+20d, XV500C00 SS, XE805101 FF+20d |  |  |  |  | 53d | 44.5d |  | TB26 - T - Construct-Winter-3 (Dec/Jan/Feb free) * | Piping insulation [650 sqm]; Piping insulation [4875 h] | 5,368.74 |  | 4875,00 |  | 2012-04-30 | E-13-01 |  |  |  |  |  |  | XV505101 | 4875 | 0 |  |  | 934 | 51 | 200 | 200 | C | LND | X | V | XV50 | 5101 | V | 51 | X | INS | LND | 5101 | VNZM |  |  |  |  |  |  |  |  |  |  |  |  |  |  |  |  |  |
|  | 02 | **CA5102** |  |  | 2008-09-24 | 2012-07-27 |  |  |  |  |  |  |  |  |  |  |  |  |  |  |  |  |  |  |  |  |  |  |  |  |  |  |  |  |  |  |  |  |  |  |  |  |  |  |  |  |  |  |  |  |  |  |  |  |  |  |  |  |  |  |  |  |  |  |  |  |  |
|  | C | **Civil Work** |  |  | 2008-09-24 | 2012-03-02 |  |  |  |  |  |  |  |  |  |  |  |  |  |  |  |  |  |  |  |  |  |  |  |  |  |  |  |  |  |  |  |  |  |  |  |  |  |  |  |  |  |  |  |  |  |  |  |  |  |  |  |  |  |  |  |  |  |  |  |  |  |
| XC115102 |  | CA51 SR5102 - Excavation&Surface Prep by U/I/O |  | 294d | 2008-09-24 A | 2009-09-30 A | XC111410 SS, XC111200 SS | 100% |  |  |  |  |  |  |  |  |  |  |  |  |  |  |  |  |  |  |  |  | XC115102 | 0 | 0 |  |  | 934 | 51 | 200 | 200 | C | UIO | X | C | XC11 | 5102 | C | 51 | X | CW | LND | 5102 | MO11 |  |  |  |  |  |  |  |  |  |  |  |  |  |  |  |  |  |
| XC11510205 |  | CA51 SR5102 - Excavation |  | 35d | 2010-02-18 A | 2010-03-30 A | XC115102 | 100% |  |  |  |  |  |  |  | Excavation [8000 cbm]; Excavation [4000 h] | 320,000 | 320,000 | 4000,00 |  |  |  |  |  |  |  |  |  | XC11510205 | 4000 | 4000 |  |  | 934 | 51 | 200 | 200 | C | MO02 | X | C | XC11 | 5102 | C | 10 | X | P | LND | 1010 | MO11 |  |  | 999 |  |  |  |  |  |  |  |  |  |  |  |  |  |  |
| XC11510210 |  | CA51 SR5102 - SubBase (Gravel/Geogrid) for Concrete |  | 5d | 2010-03-31 A | 2010-04-06 A | XC11510205 | 100% |  | 2010-03-31 | 2010-04-05 |  |  |  |  | Sub Base for Concrete/Paving&Roads (Gravel) [1000 cbm]; Subbase for Concrete [1000 h] | 100,000 | 30,000 | 1000,00 |  |  |  |  |  |  |  |  |  | XC11510210 | 1000 | 1000 |  |  | 934 | 51 | 200 | 200 | C | MO02 | X | C | XC11 | 5102 | C | 10 | X | P | LND | 1010 | MO11 |  |  | 999 |  |  |  |  |  |  |  |  |  |  |  |  |  |  |
| XC155102 |  | CA51 SR5102 - Piling |  | 11d | 2010-04-14 A | 2010-04-26 A | F2910, XC115102, XC11510205 FS+1d, XC11510210, EC155102 (other project) FS+10d, XC155101 FS-1d, P3C01D1 (other project) | 100% |  |  |  |  |  |  |  | Piles driven [225 pcs]; Piles driven [1686.5 h] | 67,500 | 67,500 | 1686,50 |  |  |  |  |  |  |  |  |  | XC155102 | 1686,5 | 1686,5 |  |  | 934 | 51 | 200 | 200 | C | MO02 | X | C | XC15 | 5102 | C | 51 | X | P | LND | 5102 | MO11 |  |  |  |  |  |  |  |  |  |  |  |  |  |  |  |  |  |
| XC205102 |  | CA51 SR5102 - Concrete Works |  | 24d | 2010-07-07 A | 2010-08-03 A | XC205101 SS-2d, EC45510215 (other project), P3C02D1 (other project), XC155102, XC200C10 FS+2d, EC285102 (other project) FS+7d | 100% |  |  |  |  |  |  | TB26 - V - Construct-Winter partly * | Concrete works [670 cbm]; Concrete works [20100 h] | 7,316.97 |  | 20100,00 |  |  |  |  |  |  |  |  |  | XC205102 | 20100 | 20100 |  |  | 934 | 51 | 200 | 200 | C | MO03 | X | C | XC20 | 5102 | C | 51 | X | mai | LND | 5102 | MO11 |  |  |  |  |  |  |  |  |  |  |  |  |  |  |  |  |  |
| XC195102 |  | CA51 SR5102 - Backfill |  | 255d | 2010-09-20 A | 2011-10-31 | XC915102 FF, XC205102 FF+5d, XC195101 SS |  | 56d |  |  | 135d | 0d |  | TB26 - T - Construct-Winter-3 (Dec/Jan/Feb free) * | Backfill & Compaction [3800 cbm]; Backfill & Compaction [5700 h] | 342,000 | 171,000 | 5700,00 |  |  |  |  |  |  |  |  |  | XC195102 | 5700 | 2850 |  |  | 934 | 51 | 200 | 200 | C | CiC | X | C | XC19 | 5102 | C | 51 | X | mai | LND | 5102 | MO11 |  |  |  | 2010-11-01 | 2010-12-01 | 27.8. | x |  |  |  |  |  |  |  |  |  |  |
| XC20510205 |  | CA51 SR5102 - Precast Concrete Elements |  | 25d | 2010-11-22 A | 2010-12-20 A | EC28510206 (other project), P3C02D2 (other project) FS+15d, XCC02D2, EC28510205 (other project) | 100% |  |  |  |  |  |  |  |  |  |  |  |  |  |  |  |  |  |  |  |  | XC20510205 | 0 | 0 |  |  | 934 | 51 | 200 | 200 | C | MO04 | X | C | XC40 | 5102 | C | 51 | X | pre | LND | 5102 | MO11 |  |  |  |  |  |  |  |  |  |  |  |  |  |  |  |  |  |
| XC20510215 |  | CA51 SR5102 - Erection Precast Elements |  | 55d | 2010-12-06 A | 2011-02-15 A | XC20510115 SS+1d, IMS-C-000030 FF, XC205102, XC20510205 SS+12d | 100% |  |  |  |  |  | finish on or after 2011-02-01 |  | Precast Concrete Works [195 cbm]; Precast concrete works [487 h] | 19,500 | 19,500 | 487,00 |  |  |  |  |  |  |  |  |  | XC20510215 | 487 | 487 |  |  | 934 | 51 | 200 | 200 | C | MO04 | X | C | XC40 | 5102 | C | 51 | X | mai | LND | 5102 | MO11 |  |  |  |  |  |  |  | Comp | x |  |  |  |  |  |  |  |  |
| XC20510220 |  | CA51 SR5102 - Erection Precast Elements finished | milestone | 0d | 2011-02-15 A | 2011-02-15 A | XC20510215 FF | 100% |  |  |  |  |  |  |  |  |  |  |  |  |  |  |  |  |  |  |  |  | XC20510220 | 0 | 0 |  |  | 934 | 51 | 200 | 200 | C | CiC | X | C | XC40 | 5102 | C | 31 | X | OB | LND | 3120 | MO11 |  |  |  |  |  |  |  |  | x | D |  |  |  |  |  |  |  |
| XC305102 |  | CA51 SR5102 - UG Installation (incl. Precast Manholes) |  | 25d | 2011-09-12 | 2011-10-10 | XC300C00, P3R02AS1 (other project), EC305102 (other project) FS+10d, XC310C00, P3C02D4 (other project) FS+10d, P3R02S1 (other project), ER445102 (other project), XC205102 FF+10d, P3R02BS (other project), P3R02S1 (other project) FF, P3R02AS1 (other project) FF |  |  |  |  | 17d | 63d | start on or after 2011-09-12 | TB26 - V - Construct-Winter partly * |  |  |  |  |  |  |  |  |  |  |  |  |  | XC305102 | 0 | 0 |  |  | 934 | 51 | 200 | 200 | C | CiC | X | C | XC30 | 5102 | C | 51 | X | mai | LND | 5102 |  |  |  |  |  |  | 27.8. |  |  |  |  | 1 |  |  |  |  |  |  |
| XC605102 |  | CA51 SR5102 - Paving |  | 20d | 2011-11-01 | 2012-03-02 | XC605101 SS+3d, XC195102, XN205102l |  |  |  |  | 135d | 0d |  | TB26 - T - Construct-Winter-3 (Dec/Jan/Feb free) * | Gravel [650 sqm]; Gravel [32 h] | 3,078.3 |  | 32,00 |  |  |  |  |  |  |  |  |  | XC605102 | 32 | 0 |  |  | 934 | 51 | 200 | 200 | C | CiC | X | C | XC60 | 5102 | C | 51 | X | PV | LND | 5102 | MO11 |  |  |  |  |  |  |  |  |  |  | 1 |  |  |  |  |  |  |
|  | N | **Structural Steel** |  |  | 2011-02-21 | 2011-09-10 |  |  |  |  |  |  |  |  |  |  |  |  |  |  |  |  |  |  |  |  |  |  |  |  |  |  |  |  |  |  |  |  |  |  |  |  |  |  |  |  |  |  |  |  |  |  |  |  |  |  |  |  |  |  |  |  |  |  |  |  |  |
| XN705102 |  | CA51 SR5102 - KMD Assy Drawings | milestone | 0d | 2011-02-21 A | 2011-02-21 A |  | 100% |  |  |  |  |  | finish on 2011-02-21 |  |  |  |  | 22t |  |  |  |  |  |  |  |  |  | XN705102 | 0 | 0 |  |  | 934 | 51 | 200 | 200 | C | LND | X | N | XN05 | 5102 | N | 51 | X | PR | LND | 5102 |  |  |  |  |  |  |  |  |  |  | KMD |  | to be confirmed | x | XNK |  |  |  |
| XN715102 |  | CA51 SR5102 - Steel Deliveries | milestone | 0d | 2011-02-25 A | 2011-02-25 A |  | 100% |  |  |  |  |  | finish on 2011-02-25 | TB26 - 3 - Construction Normal 7days * CA17 |  |  |  | 22t |  |  |  |  |  |  |  |  |  | XN715102 | 0 | 0 |  |  | 934 | 51 | 200 | 200 | C | LND | X | N | XN06 | 5102 | N | 51 | X | PR | LND | 5102 |  |  |  |  |  |  |  |  |  |  | SD |  | to be confirmed |  | XNK |  |  |  |
| XN205102l |  | CA51 SR5102 - Installation Steel Structure |  | 101d | 2011-03-23 A | 2011-07-23 A | EN685102 (other project), XR40510205, XN715102 FS+10d, XN205101l SS+5d, P3N012D (other project) FS+10d, P3N01BN (other project), XR400C00, XN705102 | 100% |  | 2011-03-23 | 2011-07-22 |  |  |  | TB26 - V - Construct-Winter partly * | Piperacks, Main structures [10030 h]; Piperacks, Main Structures [236 t] | 401,200 | 277,100 | 10030,00 |  |  | E-04-23 | t |  |  |  |  |  | XN205102l | 10030 | 6927 |  |  | 934 | 51 | 200 | 200 | C | LND | X | N | XN20 | 5102 | N | 51 | X | PR | LND | 5102 | ChSK |  |  |  |  |  |  |  |  | x |  |  |  | x | XNK | UDF_G4 |  |  |
| XN255102 |  | CA51 SR5102 - Installation fireproof castables |  | 25d | 2011-05-14 A | 2011-06-11 A | XN205102l | 100% |  |  |  |  |  |  | TB26 - V - Construct-Winter partly * |  |  |  | 230 |  |  | E-04-23 | t |  |  |  |  |  | XN255102 | 0 | 0 |  |  | 934 | 51 | 200 | 200 | C | LND | X | N | XN20 | 5102 | N | 51 | X | PR | LND | 5102 | ChSK |  |  |  |  |  |  |  |  |  |  |  |  |  | XNK |  | action by MO11 |  |
| XN405102 |  | CA51 SR5102 - Install Railings,Ladders,etc. |  | 62d | 2011-07-01 A | 2011-09-10 | XN205102l |  | 13d |  |  | 240d | 278.5d |  |  | Ladders & platforms [7 t]; Ladders & platforms [700 h] | 362.15 |  | 700,00 |  |  |  |  |  |  |  |  |  | XN405102 | 700 | 0 |  |  | 934 | 51 | 200 | 200 | C | LND | X | N | XN40 | 5102 | N | 51 | X | SS | LND | 5102 | ChSK |  |  |  |  |  | 27.8. | actual finish |  |  |  |  |  | x | XNK | UDF_G4 |  | Check Roof - Cladding |
| XN605102 |  | CA51 SR5102 - Install Gratings |  | 54d | 2011-07-11 A | 2011-09-10 | XN205102l |  | 13d |  |  | 230d | 0d |  |  | Grating [175 sqm]; Grating [656.25 h] | 1,241.67 |  | 656,25 |  |  |  |  |  |  |  |  |  | XN605102 | 656,25 | 0 |  |  | 934 | 51 | 200 | 200 | C | LND | X | N | XN60 | 5102 | N | 51 | X | SS | LND | 5102 | ChSK |  |  |  |  |  | 27.8. | actual finish |  |  |  |  |  | x | XNK | UDF_G4 |  | Check Roof - Cladding |

Notes:
- XW505101: P3 Activity Log Info: Clarification Surface / Protection during Prefab
- XC115102: P3 Activity Log Info: incl. Dewatering/Drainage
- XC155102: P3 Activity Log Info: 174 driven piles expected,20/d/machine
- XC20510215: Current Status: 07.02.2011 (O. Siegel): zum 30.01.2011 wurden die Arbeiten noch nicht / abgeschlossen(Angaben aus CPMR). Enddatum auf den 02.02.2011 verschoben. Die / Angaben von MO11 entsprechen nicht der Realitдt. / 13.01.2011 (Oxana): die Arbeiten wurden im Dez-10 angefangen. die Verlinkung / zu XC20510115 gelцscht.
- XC305102: P3 Activity Log Info: Clarification Prefab Catch Basins/pulling / pits / Current Status: 12.0.2011 (O. Siegel): nach Rьcksprache mit MO11 am 11 und / 12.Januar 11, wurde der 25-April-11 als Starttermin besprochen.
- XN715102: Scope: 09.02.2011: weight: 240 ton / Current Status: 19.02.2011 (O.Siegel): 195 tonnen sind bereits auf der / Baustelle. (die ursprьngliche Liefermenge von 122 tonnen wurde korriegiert auf / 240 tonnen).
- XN205102l: Scope: 16.02.2011 (O.Siegel): die Liefermenge von 240 t / (Angaben vom 09.02.2011) wurden gleich aufgeteilt auf lower und upper part.

| ID | WBS | Activity | Type | Duration | Start | Finish | Predecessors | Complete | Remaining | Planned start | Planned finish | Total float | Free float | Constraint | Calendar | Resources | Cost | Actual cost | TB26 Ressource Budget | UDF_CONTRACT INDICATOR | UDF_CHECK CRITICAL PATH | UDF_SELECT UPDATE PROGRESS | UDF_SAVE ACT ID | UDF_BUDGETED LABOR UNIT | UDF_ACTUAL LABOR UNIT | UDF_COMMENTS_0827 | Department | Constr. Area | PMT-Area | PMT-Schedule Org | PMT-Phase | PMT-Respons. | WBS Phase | WBS Discipline | WBS Type of Work | WBS Objects | Russia WBS Discipline (Russia) | Russia Construction Area | Russia WBS Phase | IMS | UPT | Russia WBS Objects | 4 week lookahead | Subcontractor | UDF_CONTRACT ITEM | UDF_CONTRACT START DATE | UDF_CONTRACT FINISH DATE | TB26 Semantics | TB26 Material Res Values | UDF_ELECTRICAL START | UDF_ELECTRICAL FINISH | UDF_CONTRACT FINISH DATE REV1 | UDF_CONTRACT START DATE REV1 | UDF_CHECK BASELINE | UDF_INDICATOR | UDF_Vendor Representatives | UDF_PENALIZED FINISH | Inquiry/Order No | suspend date | resume date | UDF_CHECK RESOURCE DATES | Civil item | Zeigen/n. Zeigen | UDF_Concrete |
| --- | --- | --- | --- | --- | --- | --- | --- | --- | --- | --- | --- | --- | --- | --- | --- | --- | --- | --- | --- | --- | --- | --- | --- | --- | --- | --- | --- | --- | --- | --- | --- | --- | --- | --- | --- | --- | --- | --- | --- | --- | --- | --- | --- | --- | --- | --- | --- | --- | --- | --- | --- | --- | --- | --- | --- | --- | --- | --- | --- | --- | --- | --- | --- | --- |
|  | R | **Piping** |  |  | 2011-02-21 | 2011-09-30 |  |  |  |  |  |  |  |  |  |  |  |  |  |  |  |  |  |  |  |  |  |  |  |  |  |  |  |  |  |  |  |  |  |  |  |  |  |  |  |  |  |  |  |  |  |  |  |  |  |  |  |  |  |  |  |  |  |  |
| XR205102 |  | CA51 SR5102 - Piping Prefabrication (Start w. Cooling Water Line) |  | 147d | 2011-02-21 A | 2011-09-10 | XR200C00 FS+8d, P3R06S1 (other project) FF+20d, P3R06BS1 (other project), P3R06DS1 (other project) FF+20d, ER495102 (other project) SS | 100% | 13d | 2011-02-21 | 2011-08-16 | 168d | 471.5d | start on or after 2011-02-21 |  | A/G piping prefabrication [1590 Fpi]; A/G Piping (Prefab) [5962.5 h] | 5,594.9 |  | 5962,50 | UDF_G4 | Prefabrication | 27.8. | XR205102 | 5962,5 | 2921,25 | Expected Finish 10.09.11 | 934 | 51 | 200 | 200 | C | LND | X | R | XR20 | 5102 | R | 51 | X | PRP | LND | 5102 | x | VNZM |  |  |  |  |  |  |  |  |  |  |  |  |  |  |  |  |  |  |  |  |
| XR40510210 |  | CA51 SR5102 - Piping Install after Steel Struc |  | 67d | 2011-06-25 A | 2011-09-30 | XR40510205, XN205102l, IMS-C-000190 FF |  | 30d | 2011-06-25 | 2011-09-10 | -19d | 10d |  | TB26 - V - Construct-Winter partly * | A/G piping field installation [1800 Fpi]; Control & Shut-off valves [5 pcs]; A/G Piping (Field) [11250 h]; Install Control & Shut-off Valves [26.25 h] | 15,033.54 | 350 | 11276,25 | UDF_G4 |  | 27.8. | XR40510210 | 11276,25 | 4869 | Expected Finish 30.09.11 | 934 | 51 | 200 | 200 | C | LND | X | R | XR40 | 5102 | R | 51 | X | PI | LND | 5102 |  | VNZM | E-06-03-09 |  |  |  |  |  |  |  |  |  |  |  |  |  |  |  |  |  |  |  |
|  | E | **Electrical** |  |  | 2010-07-07 | 2012-07-27 |  |  |  |  |  |  |  |  |  |  |  |  |  |  |  |  |  |  |  |  |  |  |  |  |  |  |  |  |  |  |  |  |  |  |  |  |  |  |  |  |  |  |  |  |  |  |  |  |  |  |  |  |  |  |  |  |  |  |
| XC915102 |  | CA51 SR5102 - Installation Earthing Foundations_CIVIL |  | 28d | 2010-07-07 A | 2010-08-08 A | XC205102 SS, EE905102 (other project) | 100% |  | 2010-07-07 | 2010-08-07 |  |  |  |  | Grounding & Lightning [150 pcs]; Grounding & Lightning [1687.5 h] | 67,500 | 67,500 | 1687,50 |  |  |  | XC915102 | 1687,5 | 1687,5 |  | 934 | 51 | 200 | 200 | C | LND | X | C | XE91 | 5102 | C | 51 | X | EA | LND | 5102 |  | MO11 | E-16-07-15 | 2011-03-10 | 2011-09-20 |  |  |  |  |  |  |  |  |  |  |  |  |  |  |  |  |  |
| XE405102 |  | CA51 SR5102 - Install Cable Trays |  | 40d | 2011-07-13 A | 2011-08-29 A | XN205102l, XR40510210 SS+15d, EE46510120 (other project) FF, EE46510210 (other project), P3E16S (other project) | 100% |  | 2011-07-13 | 2011-08-27 |  |  |  | TB26 - V - Construct-Winter partly * | Cable trays/conduits [1880 m]; Cable trays [5640 h] | 225,600 | 120,000 | 5640,00 | UDF_G4 |  | 27.8. | XE405102 | 5640 | 0 |  | 934 | 51 | 200 | 200 | C | LND | X | E | XE40 | 5102 | E | 51 | X | EL | LND | 5102 |  | URMA | E-15-01-01 | 2011-03-10 | 2011-05-31 | m | 2500 | 2011-05-06 | 2011-07-16 | 2011-09-15 | 2011-05-23 | x | UDF_G2 |  |  |  |  |  |  |  |  |  |
| XE705102 |  | CA51 SR5102 - Install Lighting & Small Power |  | 50d | 2011-08-23 A | 2011-10-19 | P3E03S2 (other project) FF+20d, XP341610 FS+50d, XE405102, EE76510110 (other project), EE765102 (other project) |  | 46d |  |  | 142d | 89d |  | TB26 - V - Construct-Winter partly * | Cable Pulling [600 m]; Lighting illuminates [110 pcs]; Lighting (iluminates) [1100 h]; Cable pulling [300 h] | 56,000 | 4,480 | 1400,00 |  |  |  | XE705102 | 1400 | 0 |  | 934 | 51 | 200 | 200 | C | LND | X | E | XE70 | 5102 | E | 51 | X | EL | LND | 5102 |  | URMA | E-16-03-01 | 2011-05-10 | 2012-01-31 |  |  |  |  | 2012-05-10 | 2011-08-15 |  | UDF_G2 |  |  |  |  |  |  |  |  |  |
| XE915102 |  | CA51 SR5102 - Installation Earthing Foundations_E/I |  | 10d | 2011-09-12 | 2011-09-22 | XN605102 |  |  |  |  | 230d | 268.5d |  |  |  |  |  | 170 |  |  |  | XE915102 | 0 | 0 |  | 934 | 51 | 200 | 200 | C | LND | X | E | XE91 | 5102 | E | 51 | X | EA | LND | 5102 |  | URMA | E-16-07-15 | 2011-03-10 | 2011-09-20 |  |  |  |  | 2012-02-15 | 2011-05-23 |  | UDF_G2 |  |  |  |  |  |  |  |  |  |
| XE805102 |  | CA51 SR5102 - Install Heat Tracing |  | 90d | 2011-11-14 | 2012-04-26 | P3E19S (other project), XR605102 FS-10d, E3E1950 (other project), XE800C00 SS, XE705102 FF+18d, XW505102 FF+20d |  |  |  |  | 53d | 27d |  | TB26 - V - Construct-Winter partly * | Electrical Heat Tracing [2600 m]; Electrical heat tracing [1300 h] | 52,000 |  | 1300,00 |  |  |  | XE805102 | 1300 | 0 |  | 934 | 51 | 200 | 200 | C | LND | X | E | XE80 | 5102 | E | 51 | X | HT | LND | 5102 |  | URMA | E-16-04-01 | 2011-06-20 | 2012-03-20 |  |  |  |  | 2012-06-30 | 2011-09-15 |  | UDF_G2 | 005 |  |  |  |  |  |  |  |  |
| XE505102 |  | CA51 SR5102 - Cable Pulling Electric |  | 60d | 2012-05-17 | 2012-07-27 | EE565102 (other project), XE405102 FS-5d, XE505401 SS, XE500C01 |  |  |  |  | -95.5d | 0d |  | TB26 - V - Construct-Winter partly * | Cable Pulling [17900 m]; Cable pulling [8950 h] | 358,000 |  | 8950,00 |  |  |  | XE505102 | 8950 | 0 |  | 934 | 51 | 200 | 200 | C | LND | X | E | XE50 | 5102 | E | 51 | X | EL | LND | 5102 |  | URMA | E-16-01-01 | 2011-05-20 | 2012-02-10 | m | 18500 | 2011-07-30 | 2011-10-07 | 2012-07-01 | 2011-10-01 |  | UDF_G2 |  |  |  |  |  |  |  |  |  |
|  | J | **Instrumentation** |  |  | 2011-07-04 | 2012-07-16 |  |  |  |  |  |  |  |  |  |  |  |  |  |  |  |  |  |  |  |  |  |  |  |  |  |  |  |  |  |  |  |  |  |  |  |  |  |  |  |  |  |  |  |  |  |  |  |  |  |  |  |  |  |  |  |  |  |  |
| XJ425102 |  | CA51 SR5102 - Install CableTrays Instrumentation |  | 40d | 2011-07-04 A | 2011-08-26 A | XE405102 FF, XN205102l, EJ46510210 (other project) | 100% |  | 2011-09-01 | 2011-10-17 |  |  |  | TB26 - V - Construct-Winter partly * | Main cable trays; Install Main Cable trays |  |  | 1800,00 |  |  |  | XJ425102 | 1800 | 0 |  | 934 | 51 | 200 | 200 | C | LND | X | J | XJ42 | 5102 | J | 51 | X | IN | LND | 5102 |  | URMA | E-15-01-01 | 2011-03-10 | 2011-05-31 | m | 1700 | 2011-05-06 | 2011-07-16 | 2011-09-15 | 2011-05-23 |  | UDF_G2 |  |  |  |  |  |  |  |  |  |
| XJ525102 |  | CA51 SR5102 - Pulling Instrument Cables |  | 50d | 2012-05-17 | 2012-07-16 | P3J17S (other project), P3J17S1 (other project), XE500C01, XJ425102, XJ525401 SS, XE405102, XJ321201 FS-20d |  |  |  |  | -97.5d | 0d |  | TB26 - V - Construct-Winter partly * | Multicore cables [5800 m]; Pull multicore cables [2900 h] | 116,000 |  | 2900,00 |  |  |  | XJ525102 | 2900 | 0 |  | 934 | 51 | 200 | 200 | C | LND | X | J | XJ52 | 5102 | J | 51 | X | IN | LND | 5102 |  | URMA | E-17-04-15 | 2011-03-10 | 2011-09-20 | m | 4200 | 2011-07-30 | 2011-09-26 | 2012-03-15 | 2011-08-10 |  | UDF_G2 |  | 2012-03-15 |  |  |  |  |  |  |  |
|  | W | **Painting** |  |  | 2012-01-17 | 2012-04-03 |  |  |  |  |  |  |  |  |  |  |  |  |  |  |  |  |  |  |  |  |  |  |  |  |  |  |  |  |  |  |  |  |  |  |  |  |  |  |  |  |  |  |  |  |  |  |  |  |  |  |  |  |  |  |  |  |  |  |
| XW505102 |  | CA51 SR5102 - Surf.Protection Piping |  | 65d | 2012-01-17 | 2012-04-03 | XR205102 SS+20d, XR805102 FF+19d |  |  |  |  | 53d | 0d |  |  | Piping painting [482 sqm]; Piping painting [1205 h] | 1,413.14 |  | 1205,00 |  |  |  | XW505102 | 1205 | 0 |  | 934 | 51 | 200 | 200 | C | LND | X | W | XW50 | 5102 | W | 51 | X | PA | LND | 5102 |  | VNZM |  |  |  |  |  |  |  |  |  |  |  |  |  |  |  |  |  |  |  |  |
|  | V | **Insulation** |  |  | 2012-03-01 | 2012-06-23 |  |  |  |  |  |  |  |  |  |  |  |  |  |  |  |  |  |  |  |  |  |  |  |  |  |  |  |  |  |  |  |  |  |  |  |  |  |  |  |  |  |  |  |  |  |  |  |  |  |  |  |  |  |  |  |  |  |  |
| XV505102 |  | CA51 SR5102 - Insulation Piping |  | 90d | 2012-03-01 | 2012-06-23 | XE805102 SS+20d, XE805102 FF+20d, XV500C00 SS |  |  |  |  | 53d | 44.5d |  | TB26 - T - Construct-Winter-3 (Dec/Jan/Feb free) * | Piping insulation [650 sqm]; Piping insulation [4875 h] | 5,368.74 |  | 4875,00 |  |  |  | XV505102 | 4875 | 0 |  | 934 | 51 | 200 | 200 | C | LND | X | V | XV50 | 5102 | V | 51 | X | INS | LND | 5102 |  | VNZM | E-13-01 |  | 2012-04-30 |  |  |  |  |  |  |  |  |  |  |  |  |  |  |  |  |  |
|  | 03 | **CA5103** |  |  | 2008-09-24 | 2012-08-08 |  |  |  |  |  |  |  |  |  |  |  |  |  |  |  |  |  |  |  |  |  |  |  |  |  |  |  |  |  |  |  |  |  |  |  |  |  |  |  |  |  |  |  |  |  |  |  |  |  |  |  |  |  |  |  |  |  |  |
|  | C | **Civil Work** |  |  | 2008-09-24 | 2012-03-07 |  |  |  |  |  |  |  |  |  |  |  |  |  |  |  |  |  |  |  |  |  |  |  |  |  |  |  |  |  |  |  |  |  |  |  |  |  |  |  |  |  |  |  |  |  |  |  |  |  |  |  |  |  |  |  |  |  |  |
| XC115103 |  | CA51 SR5103 - Excavation&Surface Prep by U/I/O |  | 294d | 2008-09-24 A | 2009-09-30 A | XC111300 SS | 100% |  |  |  |  |  |  |  |  |  |  |  |  |  |  | XC115103 | 0 | 0 |  | 934 | 51 | 200 | 200 | C | UIO | X | C | XC11 | 5103 | C | 51 | X | CW | LND | 5103 |  | MO11 |  |  |  |  |  |  |  |  |  |  |  |  |  |  |  |  |  |  |  |  |
| XC11510305 |  | CA51 SR5103 - Excavation |  | 30d | 2010-02-25 A | 2010-03-31 A | XC115103 | 100% |  |  |  |  |  |  |  | Excavation [6000 cbm]; Excavation [3000 h] | 240,000 | 240,000 | 3000,00 |  |  |  | XC11510305 | 3000 | 3000 |  | 934 | 51 | 200 | 200 | C | MO02 | X | C | XC11 | 5103 | C | 10 | X | P | LND | 1010 |  | MO11 |  |  |  |  |  |  |  |  |  |  |  |  |  | 999 |  |  |  |  |  |  |
| XC11510310 |  | CA51 SR5103 - SubBase (Gravel/Geogrid) for Concrete |  | 5d | 2010-04-01 A | 2010-04-07 A | XC11510305 | 100% |  | 2010-04-01 | 2010-04-06 |  |  |  |  | Sub Base for Concrete/Paving&Roads (Gravel) [800 cbm]; Subbase for Concrete [800 h] | 80,000 | 20,000 | 800,00 |  |  |  | XC11510310 | 800 | 800 |  | 934 | 51 | 200 | 200 | C | MO02 | X | C | XC11 | 5103 | C | 10 | X | P | LND | 1010 |  | MO11 |  |  |  |  |  |  |  |  |  |  |  |  |  | 999 |  |  |  |  |  |  |
| XC155103 |  | CA51 SR5103 - Piling |  | 10d | 2010-04-22 A | 2010-05-04 A | EC155103 (other project) FS+10d, XC115103, XC11510310, XC155102 SS+7d, XC11510305 FS+1d, F2910 | 100% |  |  |  |  |  |  |  | Piles driven [129 pcs]; Piles driven [967.5 h] | 38,700 | 38,700 | 967,50 |  |  |  | XC155103 | 967,5 | 967,5 |  | 934 | 51 | 200 | 200 | C | MO02 | X | C | XC15 | 5103 | C | 51 | X | P | LND | 5103 |  | MO11 |  |  |  |  |  |  |  |  |  |  |  |  |  |  |  |  |  |  |  |  |
| XC205103 |  | CA51 SR5103 - Concrete Works |  | 28d | 2010-07-16 A | 2010-08-17 A | XC205101 SS+6d, XC200C10 FS+5d, XC155103, EC285103 (other project) FS+10d, EC45510315 (other project), P3C02D1 (other project) | 100% |  |  |  |  |  |  | TB26 - V - Construct-Winter partly * | Concrete works [470 cbm]; Concrete works [14100 h] | 6,374.63 |  | 14100,00 |  |  |  | XC205103 | 14100 | 14100 |  | 934 | 51 | 200 | 200 | C | MO03 | X | C | XC20 | 5103 | C | 51 | X | mai | LND | 5103 |  | MO11 |  |  |  |  |  |  |  |  |  |  |  |  |  |  |  |  |  |  |  |  |
| XC195103 |  | CA51 SR5103 - Backfill |  | 250d | 2010-09-25 A | 2011-10-31 | XC195102 SS+5d, XC205103, XC915103 FF |  | 56d |  |  | 138d | 3d |  | TB26 - T - Construct-Winter-3 (Dec/Jan/Feb free) * | Backfill & Compaction [3100 cbm]; Backfill & Compaction [4650 h] | 279,000 | 162,000 | 4650,00 |  |  | 27.8. | XC195103 | 4650 | 2700 |  | 934 | 51 | 200 | 200 | C | CiC | X | C | XC19 | 5103 | C | 51 | X | mai | LND | 5103 |  | MO11 |  |  |  |  |  |  |  |  |  |  |  |  |  |  | 2010-11-01 | 2010-11-30 | 9.5.12 |  |  |  |
| XC20510305 |  | CA51 SR5103 - Precast Concrete Elements |  | 25d | 2010-11-24 A | 2010-12-22 A | P3C02D2 (other project) FS+5d, EC28510306 (other project), XCC02D2 FS+20d, EC28510305 (other project) | 100% |  |  |  |  |  |  |  |  |  |  |  |  |  |  | XC20510305 | 0 | 0 |  | 934 | 51 | 200 | 200 | C | MO04 | X | C | XC40 | 5103 | C | 51 | X | pre | LND | 5103 |  | MO11 |  |  |  |  |  |  |  |  |  |  |  |  |  |  |  |  |  |  |  |  |
| XC20510315 |  | CA51 SR5103 - Erection Precast Elements |  | 15d | 2011-01-17 A | 2011-02-16 A | XC20510215 SS+26d, XC205103, XC20510305 FS+5d, IMS-C-000030 FF, XC20510305 SS+12d | 100% |  |  |  |  |  |  | TB26 - V - Construct-Winter partly * | Precast Concrete Works [150 cbm]; Precast concrete works [375 h] | 15,000 | 15,000 | 375,00 |  |  |  | XC20510315 | 375 | 375 |  | 934 | 51 | 200 | 200 | C | MO04 | X | C | XC40 | 5103 | C | 51 | X | mai | LND | 5103 | x | MO11 |  |  |  |  |  |  |  |  |  |  |  |  |  |  |  |  |  | Comp |  |  |
| XC20510320 |  | CA51 SR5103 - Erection Precast Elements finished | milestone | 0d | 2011-02-16 A | 2011-02-16 A | XC20510315 FF | 100% |  |  |  |  |  |  |  |  |  |  |  |  |  |  | XC20510320 | 0 | 0 |  | 934 | 51 | 200 | 200 | C | CiC | X | C | XC40 | 5103 | C | 31 | X | OB | LND | 3120 | x | MO11 |  |  |  |  |  |  |  |  |  |  |  |  |  |  |  |  |  |  | D |  |
| XC305103 |  | CA51 SR5103 - UG Installation (incl. Precast Manholes) |  | 25d | 2011-09-12 | 2011-10-10 | XC310C00, P3R02S1 (other project) FF, P3C02D4 (other project) FS+10d, P3R02BS (other project), EC305103 (other project) FS+10d, XC300C00, P3R02AS1 (other project), P3R02AS1 (other project) FF, P3R02S1 (other project), XC205103 FF+10d, ER445103 (other project) |  |  |  |  | 17d | 63d | start on or after 2011-09-12 | TB26 - V - Construct-Winter partly * |  |  |  |  |  |  | 27.8. | XC305103 | 0 | 0 |  | 934 | 51 | 200 | 200 | C | CiC | X | C | XC30 | 5103 | C | 51 | X | mai | LND | 5103 |  |  |  |  |  |  |  |  |  |  |  |  |  |  |  |  |  |  |  |  |  | 1 |
| XC605103 |  | CA51 SR5103 - Paving |  | 20d | 2011-11-07 | 2012-03-07 | XC195103, XC605102 SS+3d, XN205103u, XN205103l |  |  |  |  | 135d | 0d |  | TB26 - T - Construct-Winter-3 (Dec/Jan/Feb free) * | Gravel [510 sqm]; Gravel [26 h] | 1,991.84 |  | 26,00 |  |  |  | XC605103 | 26 | 0 |  | 934 | 51 | 200 | 200 | C | CiC | X | C | XC60 | 5103 | C | 51 | X | PV | LND | 5103 |  | MO11 |  |  |  |  |  |  |  |  |  |  |  |  |  |  |  |  |  |  |  | 1 |

Notes:
- XE405102: UDF_PREDECESSOR: XN30, Piping 50%
- XE705102: UDF_PREDECESSOR: XE40, Civil 100%
- XE915102: UDF_PREDECESSOR: XN30, DEL XE40, DEL XE80, DEL XJ40, Civil 100%, Equipment 100%
- XE805102: UDF_PREDECESSOR: XR40, Piping 50% pressure tests
- XE505102: UDF_PREDECESSOR: XE40, XE50, DEL XE34
- XJ425102: UDF_PREDECESSOR: XE40, XJ32, Equipment 100%, Piping 50%
- XJ525102: UDF_PREDECESSOR: XE40, XJ32, XJ52
- XW505102: P3 Activity Log Info: Clarification Surface Protection during Prefab
- XC115103: P3 Activity Log Info: incl. Dewatering/Drainage
- XC155103: P3 Activity Log Info: 147 driven piles expected,20/d/machine
- XC20510315: Current Status: 13.01.2011 (Oxana): zum 01.01.2011 wurden keine Arbeiten / durchgefьhrt (Angaben aus CPMR). Startdatum auf den 31.01.2011 verschoben. / Endtermin wird gehalten (Angaben von Mostostroy).
- XC305103: P3 Activity Log Info: Clarification Prefab Catch Basins/pulling / pits / Current Status: 12.0.2011 (O. Siegel): nach Rьcksprache mit MO11 am 11 und / 12.Januar 11, wurde der 25-April-11 als Starttermin besprochen.

| ID | WBS | Activity | Type | Duration | Start | Finish | Predecessors | Complete | Remaining | Planned start | Planned finish | Total float | Free float | Constraint | Calendar | Resources | Cost | Actual cost | TB26 Ressource Budget | Comments | UDF_SAVE ACT ID | UDF_CHECK BASELINE | UDF_BUDGETED LABOR UNIT | UDF_ACTUAL LABOR UNIT | Department | Type of Work | Constr. Area | PMT-Area | PMT-Schedule Org | PMT-Phase | PMT-Respons. | Zeigen/n. Zeigen | WBS Phase | WBS Discipline | WBS Type of Work | WBS Objects | Russia WBS Discipline (Russia) | Russia Construction Area | Russia WBS Phase | IMS | UPT | Russia WBS Objects | UDF_CONTRACT ITEM | TB26 Semantics | 4 week lookahead | Subcontractor | UDF_COMMENTS | UDF_CONTRACT INDICATOR | UDF_CHECK CRITICAL PATH | UDF_SELECT UPDATE PROGRESS | UDF_CHECK RESOURCE DATES | UDF_COMMENTS_0827 | UDF_CONTRACT START DATE | UDF_CONTRACT FINISH DATE | TB26 Material Res Values | UDF_ELECTRICAL START | UDF_ELECTRICAL FINISH | UDF_CONTRACT FINISH DATE REV1 | UDF_CONTRACT START DATE REV1 | UDF_INDICATOR | UDF_Vendor Representatives | UDF_ELECTRICAL SEQUENCE | UDF_PENALIZED FINISH |
| --- | --- | --- | --- | --- | --- | --- | --- | --- | --- | --- | --- | --- | --- | --- | --- | --- | --- | --- | --- | --- | --- | --- | --- | --- | --- | --- | --- | --- | --- | --- | --- | --- | --- | --- | --- | --- | --- | --- | --- | --- | --- | --- | --- | --- | --- | --- | --- | --- | --- | --- | --- | --- | --- | --- | --- | --- | --- | --- | --- | --- | --- | --- | --- |
|  | N | **Structural Steel** |  |  | 2011-02-21 | 2011-09-10 |  |  |  |  |  |  |  |  |  |  |  |  |  |  |  |  |  |  |  |  |  |  |  |  |  |  |  |  |  |  |  |  |  |  |  |  |  |  |  |  |  |  |  |  |  |  |  |  |  |  |  |  |  |  |  |  |  |
| XN705103 |  | CA51 SR5103 - KMD Assy Drawings | milestone | 0d | 2011-02-21 A | 2011-02-21 A |  | 100% |  |  |  |  |  | finish on 2011-02-21 |  |  |  |  | 22t | to be confirmed | XN705103 | x | 0 | 0 | 934 | XNK | 51 | 200 | 200 | C | LND | KMD | X | N | XN05 | 5103 | N | 51 | X | PR | LND | 5103 |  |  |  |  |  |  |  |  |  |  |  |  |  |  |  |  |  |  |  |  |  |
| XN715103 |  | CA51 SR5103 - Steel Deliveries | milestone | 0d | 2011-02-22 A | 2011-02-22 A |  | 100% |  |  |  |  |  | finish on 2011-02-21 | TB26 - 3 - Construction Normal 7days * CA17 |  |  |  | 22t | to be confirmed | XN715103 |  | 0 | 0 | 934 | XNK | 51 | 200 | 200 | C | LND | SD | X | N | XN06 | 5103 | N | 51 | X | PR | LND | 5103 |  |  |  |  |  |  |  |  |  |  |  |  |  |  |  |  |  |  |  |  |  |
| XN205103l |  | CA51 SR5103 - Installation Steel Structure (lower part) |  | 27d | 2011-05-12 A | 2011-06-14 A | XR40510305, XN205102l SS+5d, XN705103, EN685103 (other project), XR400C00, XN715103 FS+10d, P3N012D (other project) FS+10d, P3N01CN (other project) | 100% |  | 2011-05-12 | 2011-06-11 |  |  | start on or after 2011-04-25 | TB26 - V - Construct-Winter partly * | Piperacks, Main structures [2890 h]; Piperacks, Main Structures [68 t] | 115,600 | 111,318.52 | 2890,00 |  | XN205103l |  | 2890 | 2890 | 934 | XNK | 51 | 200 | 200 | C | LND |  | X | N | XN20 | 5103 | N | 51 | X | PR | LND | 5103 | E-04-24 | t | x | ChSK |  |  |  |  |  |  |  |  |  |  |  |  |  |  |  |  |  |
| XN255103 |  | CA51 SR5103 - Installation fireproof castables |  | 5d | 2011-05-21 A | 2011-05-26 A | XN205103l | 100% |  |  |  |  |  |  | TB26 - V - Construct-Winter partly * |  |  |  | 170 |  | XN255103 |  | 0 | 0 | 934 | XNK | 51 | 200 | 200 | C | LND |  | X | N | XN20 | 5103 | N | 51 | X | PR | LND | 5103 | E-04-24 | t |  | ChSK | action by MO11 |  |  |  |  |  |  |  |  |  |  |  |  |  |  |  |  |
| XN205103u |  | CA51 SR5103 - Installation Steel Structure (upper part) |  | 50d | 2011-05-27 A | 2011-06-24 A | XN715103 FS+10d, XN705103, XN255103 | 100% |  | 2011-05-27 | 2011-07-25 |  |  |  | TB26 - V - Construct-Winter partly * | Piperacks, Main structures [3570 h]; Piperacks, Main Structures [84 t] | 142,800 | 84,936.8 | 3570,00 |  | XN205103u |  | 3570 | 3570 | 934 | XNK | 51 | 200 | 200 | C | LND |  | X | N | XN20 | 5103 | N | 51 | X | PR | LND | 5103 | E-04-24 | t |  | ChSK |  |  |  |  |  |  |  |  |  |  |  |  |  |  |  |  |  |
| XN405103 |  | CA51 SR5103 - Install Railings,Ladders,etc. |  | 67d | 2011-06-25 A | 2011-09-10 | XN205103u, XN205103l |  | 13d |  |  | 240d | 278.5d |  |  | Ladders & platforms [4 t]; Ladders & platforms [400 h] | 362.15 |  | 400,00 |  | XN405103 | x | 400 | 100 | 934 | XNK | 51 | 200 | 200 | C | LND |  | X | N | XN40 | 5103 | N | 51 | X | SS | LND | 5103 |  |  |  | ChSK |  | UDF_G4 | Check Roof - Cladding | 27.8. | actual finish |  |  |  |  |  |  |  |  |  |  |  |  |
| XN605103 |  | CA51 SR5103 - Install Gratings |  | 67d | 2011-06-25 A | 2011-09-10 | XN205103u, XN205103l |  | 13d |  |  | 240d | 278.5d |  |  | Grating [90 sqm]; Grating [337.5 h] |  |  | 337,50 |  | XN605103 | x | 337,5 | 0 | 934 | XNK | 51 | 200 | 200 | C | LND |  | X | N | XN60 | 5103 | N | 51 | X | SS | LND | 5103 |  |  |  | ChSK |  | UDF_G4 | Check Roof - Cladding | 27.8. | actual finish |  |  |  |  |  |  |  |  |  |  |  |  |
|  | R | **Piping** |  |  | 2011-02-21 | 2011-09-30 |  |  |  |  |  |  |  |  |  |  |  |  |  |  |  |  |  |  |  |  |  |  |  |  |  |  |  |  |  |  |  |  |  |  |  |  |  |  |  |  |  |  |  |  |  |  |  |  |  |  |  |  |  |  |  |  |  |
| XR205103 |  | CA51 SR5103 - Piping Prefabrication (Start w. Cooling Water Line) |  | 147d | 2011-02-21 A | 2011-09-10 | A1KL0020 (other project) FF+10d, P3R06S1 (other project) FF+20d, P3R06DS1 (other project) FF+20d, XR200C00 FS+12d, P3R06BS1 (other project) FS+10d, ER495103 (other project) SS | 100% | 13d | 2011-02-21 | 2011-08-16 | 424.5d | 471.5d | start on or after 2011-02-28 |  | A/G piping prefabrication [1590 Fpi]; A/G Piping (Prefab) [5962.5 h] | 5,594.9 |  | 5962,50 |  | XR205103 |  | 5962,5 | 2921,25 | 934 |  | 51 | 200 | 200 | C | LND |  | X | R | XR20 | 5103 | R | 51 | X | PRP | LND | 5103 |  |  | x | VNZM |  | UDF_G4 | Prefabrication | 27.8. |  | Expected Finish 10.09.11 |  |  |  |  |  |  |  |  |  |  |  |
| XR40510310 |  | CA51 SR5103 - Piping Install after Steel Struc |  | 84d | 2011-06-25 A | 2011-09-30 | XR40510305, XN205103l, XN205103u, IMS-C-000190 FF |  | 30d |  |  | -11d | 18d |  | TB26 - V - Construct-Winter partly * | A/G piping field installation [1800 Fpi]; Control & Shut-off valves [5 pcs]; Install Control & Shut-off Valves [26.25 h]; A/G Piping (Field) [11250 h] | 15,033.54 | 675 | 11276,25 |  | XR40510310 |  | 11276,25 | 4869 | 934 |  | 51 | 200 | 200 | C | LND |  | X | R | XR40 | 5103 | R | 51 | X | PI | LND | 5103 | E-06-03-09 |  |  | VNZM |  | UDF_G4 |  | 27.8. | x | Expected Finish 30.09.11 |  |  |  |  |  |  |  |  |  |  |  |
|  | E | **Electrical** |  |  | 2010-07-16 | 2012-08-08 |  |  |  |  |  |  |  |  |  |  |  |  |  |  |  |  |  |  |  |  |  |  |  |  |  |  |  |  |  |  |  |  |  |  |  |  |  |  |  |  |  |  |  |  |  |  |  |  |  |  |  |  |  |  |  |  |  |
| XC915103 |  | CA51 SR5103 - Installation Earthing Foundations_CIVIL |  | 27d | 2010-07-16 A | 2010-08-16 A | XC205103 SS, EE905103 (other project) | 100% |  |  |  |  |  |  |  | Grounding & Lightning [150 pcs]; Grounding & Lightning [1687.5 h] | 67,500 | 67,500 | 1687,50 |  | XC915103 |  | 1687,5 | 1687,5 | 934 |  | 51 | 200 | 200 | C | LND |  | X | C | XE91 | 5103 | C | 51 | X | EA | LND | 5103 | E-16-07-15 |  |  | MO11 |  |  |  |  |  |  | 2011-03-10 | 2011-09-20 |  |  |  |  |  |  |  |  |  |
| XE405103 |  | CA51 SR5103 - Install Cable Trays |  | 56d | 2011-06-17 A | 2011-08-20 A | EE46510310 (other project), XN205103l, XN205103u, P3E16S (other project) | 100% |  |  |  |  |  |  | TB26 - V - Construct-Winter partly * | Cable trays/conduits [1880 m]; Cable trays [5640 h] | 225,600 | 1,200 | 5640,00 |  | XE405103 | x | 5640 | 30 | 934 |  | 51 | 200 | 200 | C | LND |  | X | E | XE40 | 5103 | E | 51 | X | EL | LND | 5103 | E-15-01-01 | m |  | URMA |  | UDF_G4 |  | 27.8. |  |  | 2011-03-10 | 2011-05-31 | 2500 | 2011-05-19 | 2011-07-28 | 2011-09-15 | 2011-05-23 | UDF_G2 |  |  |  |
| XE705103 |  | CA51 SR5103 - Install Lighting & Small Power |  | 50d | 2011-08-23 A | 2011-10-19 | EE765103 (other project), XP341610 FS+50d, XE405103, P3E03S2 (other project) FF+20d, XN605102 |  | 46d |  |  | 148d | 70d |  | TB26 - V - Construct-Winter partly * | Cable Pulling [600 m]; Lighting illuminates [110 pcs]; Lighting (iluminates) [1100 h]; Cable pulling [300 h] | 56,000 | 4,480 | 1400,00 |  | XE705103 |  | 1400 | 0 | 934 |  | 51 | 200 | 200 | C | LND |  | X | E | XE70 | 5103 | E | 51 | X | EL | LND | 5103 | E-16-03-01 |  |  | URMA |  |  |  | 27.8. | ok |  | 2011-05-10 | 2012-01-31 |  |  |  | 2012-05-10 | 2011-08-15 | UDF_G2 |  |  |  |
| XE915103 |  | CA51 SR5103 - Installation Earthing Foundations_E/I |  | 10d | 2011-08-27 | 2011-09-07 | XN205103u, XJ425103, XE405103 |  |  |  |  | 243d | 281.5d |  |  |  |  |  | 170 |  | XE915103 |  | 0 | 0 | 934 |  | 51 | 200 | 200 | C | LND |  | X | E | XE91 | 5103 | E | 51 | X | EA | LND | 5103 | E-16-07-15 |  |  | URMA |  |  |  |  |  |  | 2011-03-10 | 2011-09-20 |  |  |  | 2012-02-15 | 2011-05-23 | UDF_G2 |  |  |  |
| XE805103 |  | CA51 SR5103 - Install Heat Tracing |  | 70d | 2011-11-03 | 2012-03-27 | E3E1950 (other project), XE705103 FF+12d, P3E19S (other project), XR605103 FS-10d |  |  |  |  | 78d | 32d |  | TB26 - V - Construct-Winter partly * | Electrical Heat Tracing [2600 m]; Electrical heat tracing [1300 h] | 52,000 |  | 1300,00 |  | XE805103 |  | 1300 | 0 | 934 |  | 51 | 200 | 200 | C | LND |  | X | E | XE80 | 5103 | E | 51 | X | HT | LND | 5103 | E-16-04-01 |  |  | URMA |  |  |  |  |  |  | 2011-06-20 | 2012-03-20 |  |  |  | 2012-06-30 | 2011-09-15 | UDF_G2 | 005 |  |  |
| XE505103 |  | CA51 SR5103 - Cable Pulling Electric |  | 60d | 2012-05-29 | 2012-08-08 | XE505102 SS+10d, XE500C01, EE565103 (other project), XE405103 |  |  |  |  | -95.5d | 0d |  | TB26 - V - Construct-Winter partly * | Cable Pulling [17900 m]; Cable pulling [8950 h] | 358,000 |  | 8950,00 |  | XE505103 |  | 8950 | 0 | 934 |  | 51 | 200 | 200 | C | LND |  | X | E | XE50 | 5103 | E | 51 | X | EL | LND | 5103 | E-16-01-01 | m |  | URMA |  |  |  |  |  |  | 2011-05-20 | 2012-02-10 | 18500 | 2011-08-13 | 2011-10-21 | 2012-07-01 | 2011-10-01 | UDF_G2 |  | XJ321321 |  |
|  | J | **Instrumentation** |  |  | 2011-07-04 | 2012-07-16 |  |  |  |  |  |  |  |  |  |  |  |  |  |  |  |  |  |  |  |  |  |  |  |  |  |  |  |  |  |  |  |  |  |  |  |  |  |  |  |  |  |  |  |  |  |  |  |  |  |  |  |  |  |  |  |  |  |
| XJ425103 |  | CA51 SR5103 - Install CableTrays Instrumentation |  | 47d | 2011-07-04 A | 2011-08-26 A | EJ46510310 (other project), XN205103u, XE405103 FF | 100% |  |  |  |  |  |  | TB26 - V - Construct-Winter partly * | Main cable trays [600 m]; Install Main Cable trays [1800 h] | 72,000 |  | 1800,00 |  | XJ425103 |  | 1800 | 0 | 934 |  | 51 | 200 | 200 | C | LND |  | X | J | XJ42 | 5103 | J | 51 | X | IN | LND | 5103 | E-15-01-01 | m |  | URMA |  |  |  |  |  |  | 2011-03-10 | 2011-05-31 | 1700 | 2011-05-19 | 2011-07-28 | 2011-09-15 | 2011-05-23 | UDF_G2 |  |  |  |
| XJ525103 |  | CA51 SR5103 - Pulling Instrument Cables |  | 50d | 2012-05-17 | 2012-07-16 | XJ525102 SS, XJ425103, P3J17S1 (other project), P3J17S (other project), XE500C01 |  |  |  |  | -24.5d | 0d |  | TB26 - V - Construct-Winter partly * | Multicore cables [5800 m]; Pull multicore cables [2900 h] | 116,000 |  | 2900,00 |  | XJ525103 |  | 2900 | 0 | 934 |  | 51 | 200 | 200 | C | LND |  | X | J | XJ52 | 5103 | J | 51 | X | IN | LND | 5103 | E-17-04-15 | m |  | URMA |  |  |  |  |  |  | 2011-03-10 | 2011-09-20 | 4200 | 2011-08-20 | 2011-10-17 | 2012-03-15 | 2011-08-10 | UDF_G2 |  |  | 2012-03-15 |
|  | W | **Painting** |  |  | 2012-01-23 | 2012-04-03 |  |  |  |  |  |  |  |  |  |  |  |  |  |  |  |  |  |  |  |  |  |  |  |  |  |  |  |  |  |  |  |  |  |  |  |  |  |  |  |  |  |  |  |  |  |  |  |  |  |  |  |  |  |  |  |  |  |
| XW505103 |  | CA51 SR5103 - Surf.Protection Piping |  | 60d | 2012-01-23 | 2012-04-03 | XR205103 SS+20d, XR805103 FF+19d |  |  |  |  | 304.5d |  |  |  | Piping painting [482 sqm]; Piping painting [1205 h] | 1,413.14 |  | 1205,00 |  | XW505103 |  | 1205 | 0 | 934 |  | 51 | 200 | 200 | C | LND |  | X | W | XW50 | 5103 | W | 51 | X | PA | LND | 5103 |  |  |  | VNZM |  |  |  |  |  |  |  |  |  |  |  |  |  |  |  |  |  |
|  | V | **Insulation** |  |  | 2012-03-01 | 2012-06-23 |  |  |  |  |  |  |  |  |  |  |  |  |  |  |  |  |  |  |  |  |  |  |  |  |  |  |  |  |  |  |  |  |  |  |  |  |  |  |  |  |  |  |  |  |  |  |  |  |  |  |  |  |  |  |  |  |  |
| XV505103 |  | CA51 SR5103 - Insulation Piping |  | 90d | 2012-03-01 | 2012-06-23 | XE805103 SS+20d, XV500C00 SS, XE805103 FF+20d |  |  |  |  | 53d | 44.5d |  | TB26 - T - Construct-Winter-3 (Dec/Jan/Feb free) * | Piping insulation [650 sqm]; Piping insulation [4875 h] | 5,368.74 |  | 4875,00 |  | XV505103 |  | 4875 | 0 | 934 |  | 51 | 200 | 200 | C | LND |  | X | V | XV50 | 5103 | V | 51 | X | INS | LND | 5103 | E-13-01 |  |  | VNZM |  |  |  |  |  |  |  | 2012-04-30 |  |  |  |  |  |  |  |  |  |

Notes:
- XN715103: Scope: 09.02.2011: weight: 153 ton / Current Status: 19.02.2011 (O.Siegel): auf der Baustelle wurden bis heute / 56 tonnen geliefert, gesamtmenge betrдgt 68 tonnen (die urpsrьngliche Menge von / 85 tonnen wurde auf 68 tonnen reduziert).
- XN205103l: Scope: 16.02.2011 (O.Siegel): die Liefermenge von 153 t / (Angaben vom 09.02.2011) wurden aufgeteilt auf lower (77 t) und upper (76 / t) part.
- XN205103u: Scope: 16.02.2011 (O.Siegel): die Liefermenge von 153 t / (Angaben vom 09.02.2011) wurden aufgeteilt auf lower (77 t) und upper (76 / t) part.
- XE405103: UDF_PREDECESSOR: XN30, Piping 50%
- XE705103: UDF_PREDECESSOR: XE40, Civil 100%
- XE915103: UDF_PREDECESSOR: XN30, DEL XE40, DEL XE80, DEL XJ40, Civil 100%, Equipment 100%
- XE805103: UDF_PREDECESSOR: XR40, Piping 50% pressure tests
- XE505103: UDF_PREDECESSOR: XE40, XE50, DEL XE34
- XJ425103: UDF_PREDECESSOR: XE40, XJ32, Equipment 100%, Piping 50%
- XJ525103: UDF_PREDECESSOR: XE40, XJ32, XJ52
- XW505103: P3 Activity Log Info: Clarification Surface Protection during Prefab

| ID | WBS | Activity | Type | Duration | Start | Finish | Predecessors | Complete | Remaining | Planned start | Planned finish | Total float | Free float | Constraint | Calendar | Resources | Cost | Actual cost | TB26 Ressource Budget | UDF_CONTRACT INDICATOR | UDF_CHECK CRITICAL PATH | UDF_SELECT UPDATE PROGRESS | UDF_SAVE ACT ID | UDF_CHECK BASELINE | UDF_BUDGETED LABOR UNIT | UDF_ACTUAL LABOR UNIT | UDF_CHECK RESOURCE DATES | Department | Type of Work | Constr. Area | PMT-Area | PMT-Schedule Org | PMT-Phase | PMT-Respons. | WBS Phase | WBS Discipline | WBS Type of Work | WBS Objects | Russia WBS Discipline (Russia) | Russia Construction Area | Russia WBS Phase | IMS | UPT | Russia WBS Objects | Subcontractor | Inquiry/Order No | suspend date | resume date | Civil item | 4 week lookahead | Zeigen/n. Zeigen | UDF_Concrete | Comments | UDF_CONTRACT ITEM | TB26 Semantics | UDF_COMMENTS | UDF_COMMENTS_0827 |
| --- | --- | --- | --- | --- | --- | --- | --- | --- | --- | --- | --- | --- | --- | --- | --- | --- | --- | --- | --- | --- | --- | --- | --- | --- | --- | --- | --- | --- | --- | --- | --- | --- | --- | --- | --- | --- | --- | --- | --- | --- | --- | --- | --- | --- | --- | --- | --- | --- | --- | --- | --- | --- | --- | --- | --- | --- | --- |
|  | 04 | **CA5104** |  |  | 2008-09-24 | 2012-08-15 |  |  |  |  |  |  |  |  |  |  |  |  |  |  |  |  |  |  |  |  |  |  |  |  |  |  |  |  |  |  |  |  |  |  |  |  |  |  |  |  |  |  |  |  |  |  |  |  |  |  |  |
| XN405104 |  | CA51 SR5104 - Install Railings,Ladders,etc. |  | 121d | 2011-04-20 A | 2011-09-10 | XN205104u, XN205104l |  | 13d |  |  | 240d | 278.5d |  |  | Ladders & platforms [6 t]; Ladders & platforms [600 h] | 362.15 |  | 600,00 | UDF_G4 | Check Roof - Cladding | 27.8. | XN405104 | x | 600 | 100 | actual finish | 934 | XNK | 51 | 200 | 200 | C | LND | X | N | XN40 | 5104 | N | 51 | X | SS | LND | 5104 | ChSK |  |  |  |  |  |  |  |  |  |  |  |  |
|  | C | **Civil Work** |  |  | 2008-09-24 | 2012-03-13 |  |  |  |  |  |  |  |  |  |  |  |  |  |  |  |  |  |  |  |  |  |  |  |  |  |  |  |  |  |  |  |  |  |  |  |  |  |  |  |  |  |  |  |  |  |  |  |  |  |  |  |
| XC115104 |  | CA51 SR5104 - Excavation&Surface Prep by U/I/O |  | 294d | 2008-09-24 A | 2009-09-30 A | XC111300 SS | 100% |  |  |  |  |  |  |  |  |  |  |  |  |  |  | XC115104 |  | 0 | 0 |  | 934 |  | 51 | 200 | 200 | C | UIO | X | C | XC11 | 5104 | C | 51 | X | CW | LND | 5104 | MO11 |  |  |  |  |  |  |  |  |  |  |  |  |
| XC11510405 |  | CA51 SR5104 - Excavation |  | 28d | 2010-02-22 A | 2010-03-25 A | XC115104 | 100% |  |  |  |  |  |  |  | Excavation [6000 cbm]; Excavation [3000 h] | 240,000 | 240,000 | 3000,00 |  |  |  | XC11510405 |  | 3000 | 3000 |  | 934 |  | 51 | 200 | 200 | C | MO02 | X | C | XC11 | 5104 | C | 10 | X | P | LND | 1010 | MO11 | 999 |  |  |  |  |  |  |  |  |  |  |  |
| XC11510410 |  | CA51 SR5104 - SubBase (Gravel/Geogrid) for Concrete |  | 5d | 2010-04-01 A | 2010-04-07 A | XC11510405 | 100% |  | 2010-04-01 | 2010-04-06 |  |  |  |  | Sub Base for Concrete/Paving&Roads (Gravel) [700 cbm]; Subbase for Concrete [700 h] | 70,000 | 20,000 | 700,00 |  |  |  | XC11510410 |  | 700 | 700 |  | 934 |  | 51 | 200 | 200 | C | MO02 | X | C | XC11 | 5104 | C | 10 | X | P | LND | 1010 | MO11 | 999 |  |  |  |  |  |  |  |  |  |  |  |
| XC155104 |  | CA51 SR5104 - Piling |  | 13d | 2010-04-29 A | 2010-05-14 A | XC155103 SS+6d, F2910, XC11510405 FS+4d, EC155104 (other project) FS+10d, XC115104, XC11510410 FS+5d | 100% |  |  |  |  |  |  |  | Piles driven [90 pcs]; Piles driven [675 h] | 27,000 | 27,000 | 675,00 |  |  |  | XC155104 |  | 675 | 675 |  | 934 |  | 51 | 200 | 200 | C | MO02 | X | C | XC15 | 5104 | C | 51 | X | P | LND | 5104 | MO11 |  |  |  |  |  |  |  |  |  |  |  |  |
| XC15510405 |  | CA51 SR5104 - Piling (remaining) |  | 11d | 2010-07-19 A | 2010-07-30 A | XC155104, EC155104 (other project) | 100% |  |  |  |  |  |  |  |  |  |  | 30 |  |  |  | XC15510405 |  | 0 | 0 |  | 934 |  | 51 | 200 | 200 | C | MO02 | X | C | XC15 | 5104 | C | 51 | X | P | LND | 5104 | MO11 |  |  |  |  |  |  |  |  |  |  |  |  |
| XC205104 |  | CA51 SR5104 - Concrete Works |  | 37d | 2010-07-20 A | 2010-08-31 A | XC205103 SS+3d, XC200C10 FS+5d, EC285104 (other project) FS+10d, XC15510405 FF+5d, EC45510415 (other project) FS+20d, XC155104 SS+35d, P3C02D1 (other project) | 100% |  |  |  |  |  |  | TB26 - V - Construct-Winter partly * | Concrete works [290 cbm]; Concrete works [8700 h] | 5,617.07 |  | 8700,00 |  |  |  | XC205104 |  | 8700 | 8700 |  | 934 |  | 51 | 200 | 200 | C | MO03 | X | C | XC20 | 5104 | C | 51 | X | mai | LND | 5104 | MO11 |  |  |  |  |  |  |  |  |  |  |  |  |
| XC195104 |  | CA51 SR5104 - Backfill |  | 250d | 2010-09-25 A | 2011-10-31 | XC915104 FF, XC195103 SS, XC205104 |  | 56d |  |  | 141d | 6d |  | TB26 - T - Construct-Winter-3 (Dec/Jan/Feb free) * | Backfill & Compaction [1800 cbm]; Backfill & Compaction [2700 h] | 162,000 | 108,000 | 2700,00 |  |  | 27.8. | XC195104 |  | 2700 | 1800 | 15.8.12 | 934 |  | 51 | 200 | 200 | C | CiC | X | C | XC19 | 5104 | C | 51 | X | mai | LND | 5104 | MO11 |  | 2010-11-01 | 2010-11-30 |  |  |  |  |  |  |  |  |  |
| XC20510405 |  | CA51 SR5104 - Precast Concrete Elements |  | 25d | 2010-11-26 A | 2010-12-24 A | XCC02D2 FS+20d, EC28510405 (other project), P3C02D2 (other project) FS+3d, EC28510406 (other project) | 100% |  |  |  |  |  |  |  |  |  |  |  |  |  |  | XC20510405 |  | 0 | 0 |  | 934 |  | 51 | 200 | 200 | C | MO04 | X | C | XC40 | 5104 | C | 51 | X | pre | LND | 5104 | MO11 |  |  |  |  |  |  |  |  |  |  |  |  |
| XC20510415 |  | CA51 SR5104 - Erection Precast Elements |  | 10d | 2011-02-01 A | 2011-02-25 A | IMS-C-000030 FF, XC20510315 SS, XC20510405 SS+12d, XC205104 | 100% |  | 2011-02-01 | 2011-02-22 |  |  | start on or after 2011-02-01 | TB26 - V - Construct-Winter partly * | Precast Concrete Works [95 cbm]; Precast concrete works [237.5 h] | 9,500 | 9,500 | 237,50 |  |  |  | XC20510415 |  | 237,5 | 237,5 |  | 934 |  | 51 | 200 | 200 | C | MO04 | X | C | XC40 | 5104 | C | 51 | X | mai | LND | 5104 | MO11 |  |  |  | Comp | x |  |  |  |  |  |  |  |
| XC20510420 |  | CA51 SR5104 - Erection Precast Elements finished | milestone | 0d | 2011-02-28 A | 2011-02-28 A | XC20510415 FF | 100% |  |  |  |  |  |  |  |  |  |  |  |  |  |  | XC20510420 |  | 0 | 0 |  | 934 |  | 51 | 200 | 200 | C | CiC | X | C | XC40 | 5104 | C | 31 | X | OB | LND | 3120 | MO11 |  |  |  |  | x | D |  |  |  |  |  |  |
| XC305104 |  | CA51 SR5104 - UG Installation (incl. Precast Manholes) |  | 25d | 2011-09-12 | 2011-10-10 | P3R02S1 (other project), EC305104 (other project) FS+10d, P3R02AS1 (other project), XC205104 FF+10d, P3R02S1 (other project) FF, P3R02BS (other project), ER445104 (other project), XC300C00, XC310C00, P3C02D4 (other project) FS+10d, P3R02AS1 (other project) FF |  |  |  |  | 17d | 63d | start on or after 2011-09-12 | TB26 - V - Construct-Winter partly * |  |  |  |  |  |  | 27.8. | XC305104 |  | 0 | 0 |  | 934 |  | 51 | 200 | 200 | C | CiC | X | C | XC30 | 5104 | C | 51 | X | mai | LND | 5104 |  |  |  |  |  |  |  | 1 |  |  |  |  |  |
| XC605104 |  | CA51 SR5104 - Paving |  | 20d | 2011-11-10 | 2012-03-13 | XC195104, XC605103 SS+3d, XN205104u, XN205104l |  |  |  |  | 135d | 126.5d |  | TB26 - T - Construct-Winter-3 (Dec/Jan/Feb free) * | Gravel [320 sqm]; Gravel [16 h] | 3,070.91 |  | 16,00 |  |  |  | XC605104 |  | 16 | 0 |  | 934 |  | 51 | 200 | 200 | C | CiC | X | C | XC60 | 5104 | C | 51 | X | PV | LND | 5104 | MO11 |  |  |  |  |  |  | 1 |  |  |  |  |  |
|  | N | **Structural Steel** |  |  | 2011-02-21 | 2011-06-21 |  |  |  |  |  |  |  |  |  |  |  |  |  |  |  |  |  |  |  |  |  |  |  |  |  |  |  |  |  |  |  |  |  |  |  |  |  |  |  |  |  |  |  |  |  |  |  |  |  |  |  |
| XN705104 |  | CA51 SR5104 - KMD Assy Drawings | milestone | 0d | 2011-02-21 A | 2011-02-21 A |  | 100% |  |  |  |  |  | finish on 2011-02-21 |  |  |  |  | 22t |  |  |  | XN705104 | x | 0 | 0 |  | 934 | XNK | 51 | 200 | 200 | C | LND | X | N | XN05 | 5104 | N | 51 | X | PR | LND | 5104 |  |  |  |  |  |  | KMD |  | to be confirmed |  |  |  |  |
| XN715104 |  | CA51 SR5104 - Steel Deliveries | milestone | 0d | 2011-03-01 A | 2011-03-01 A |  | 100% |  |  |  |  |  | finish on 2011-02-28 | TB26 - 3 - Construction Normal 7days * CA17 |  |  |  | 22t |  |  |  | XN715104 |  | 0 | 0 |  | 934 | XNK | 51 | 200 | 200 | C | LND | X | N | XN06 | 5104 | N | 51 | X | PR | LND | 5104 |  |  |  |  |  |  | SD |  |  |  |  |  |  |
| XN205104l |  | CA51 SR5104 - Installation Steel Structure (lower part) |  | 54d | 2011-03-28 A | 2011-05-31 A | EN685104 (other project), XR400C00, P3N01DN (other project), P3N012D (other project) FS+10d, XN705104, XN715104 FS+10d, XR40510405 | 100% |  |  |  |  |  |  | TB26 - V - Construct-Winter partly * | Piperacks, Main structures [850 h]; Piperacks, Main Structures [20 t] | 34,000 | 34,000 | 850,00 |  |  |  | XN205104l |  | 850 | 850 |  | 934 | XNK | 51 | 200 | 200 | C | LND | X | N | XN20 | 5104 | N | 51 | X | PR | LND | 5104 | ChSK |  |  |  |  | x |  |  |  | E-04-25 | t |  |  |
| XN255104 |  | CA51 SR5104 - Installation fireproof castables |  | 8d | 2011-04-18 A | 2011-04-26 A | XN205104l | 100% |  |  |  |  |  |  | TB26 - V - Construct-Winter partly * |  |  |  | 110 |  |  |  | XN255104 |  | 0 | 0 |  | 934 | XNK | 51 | 200 | 200 | C | LND | X | N | XN20 | 5104 | N | 51 | X | PR | LND | 5104 | ChSK |  |  |  |  |  |  |  |  | E-04-25 | t | action by MO11 |  |
| XN205104u |  | CA51 SR5104 - Installation Steel Structure (upper part) |  | 50d | 2011-04-20 A | 2011-06-21 A | XN715104 FS+10d, XN705104, XN255104 | 100% |  | 2011-04-20 | 2011-06-20 |  |  |  | TB26 - V - Construct-Winter partly * | Piperacks, Main structures [3612.5 h]; Piperacks, Main Structures [85 t] | 144,500 | 141,215.91 | 3612,50 |  |  |  | XN205104u |  | 3612,5 | 3612,5 |  | 934 | XNK | 51 | 200 | 200 | C | LND | X | N | XN20 | 5104 | N | 51 | X | PR | LND | 5104 | ChSK |  |  |  |  |  |  |  |  | E-04-25 | t |  |  |
|  | R | **Piping** |  |  | 2011-02-21 | 2011-09-30 |  |  |  |  |  |  |  |  |  |  |  |  |  |  |  |  |  |  |  |  |  |  |  |  |  |  |  |  |  |  |  |  |  |  |  |  |  |  |  |  |  |  |  |  |  |  |  |  |  |  |  |
| XR205104 |  | CA51 SR5104 - Piping Prefabrication (Start w. Cooling Water Line) |  | 147d | 2011-02-21 A | 2011-09-10 | XR200C00 FS+12d, P3R06AS1 (other project) FF+20d, ER495104 (other project) SS, P3R06S1 (other project) FF+20d, P3R06BS1 (other project) FS+10d, P3R06DS1 (other project) FF+20d | 100% | 13d | 2011-02-21 | 2011-08-16 | 424.5d | 471.5d | start on or after 2011-03-07 |  | A/G piping prefabrication [1590 Fpi]; A/G Piping (Prefab) [5962.5 h] | 5,594.9 |  | 5962,50 | UDF_G4 | Prefabrication | 27.8. | XR205104 |  | 5962,5 | 2921,25 |  | 934 |  | 51 | 200 | 200 | C | LND | X | R | XR20 | 5104 | R | 51 | X | PRP | LND | 5104 | VNZM |  |  |  |  | x |  |  |  |  |  |  | Expected Finish 10.09.11 |
| XR40510410 |  | CA51 SR5104 - Piping Install after Steel Struc |  | 84d | 2011-06-25 A | 2011-09-30 | XN205104u, XE405104 SS+6d, XR40510405, IMS-C-000190 FF |  | 30d |  |  | 20d | 18d |  | TB26 - V - Construct-Winter partly * | A/G piping field installation [1800 Fpi]; Control & Shut-off valves [5 pcs]; A/G Piping (Field) [11250 h]; Install Control & Shut-off Valves [26.25 h] | 15,033.54 | 675 | 11276,25 | UDF_G4 |  | 27.8. | XR40510410 |  | 11276,25 | 4869 | x | 934 |  | 51 | 200 | 200 | C | LND | X | R | XR40 | 5104 | R | 51 | X | PI | LND | 5104 | VNZM |  |  |  |  |  |  |  |  | E-06-03-09 |  |  | Expected Finish 30.09.11 |

Notes:
- XC115104: P3 Activity Log Info: incl. Dewatering/Drainage
- XC155104: P3 Activity Log Info: 174 driven piles expected,20/d/machine
- XC15510405: P3 Activity Log Info: 174 driven piles expected,20/d/machine
- XC20510415: Current Status: 07.02.2011 (Oxana): zum 01.02.2011 wurden keine Arbeiten durchgefьhrt / (Angaben aus CPMR). Startdatum auf den 02.02.2011 verschoben. / Endtermin soll gehalten werden (Angaben von Mostostroy). / 13.01.2011 (Oxana): zum 01.01.2011 wurden keine Arbeiten durchgefьhrt / (Angaben aus CPMR). Startdatum auf den 31.01.2011 verschoben. Endtermin wird / gehalten (Angaben von Mostostroy).
- XC305104: P3 Activity Log Info: Clarification Prefab Catch Basins/pulling / pits / Current Status: 12.0.2011 (O. Siegel): nach Rьcksprache mit MO11 am 11 und / 12.Januar 11, wurde der 25-April-11 als Starttermin besprochen.
- XN715104: Scope: 09.02.2011: weight: 153 ton
- XN205104l: Scope: 16.02.2011 (O.Siegel): die Liefermenge von 108 t / (Angaben vom 09.02.2011) wurden gleich aufgeteilt auf lower und / upper part.
- XN205104u: Scope: 16.02.2011 (O.Siegel): die Liefermenge von 108 t / (Angaben vom 09.02.2011) wurden aufgeteilt auf lower und upper part.

| ID | WBS | Activity | Type | Duration | Start | Finish | Predecessors | Complete | Remaining | Planned start | Planned finish | Total float | Free float | Constraint | Calendar | Resources | Cost | Actual cost | TB26 Ressource Budget | UDF_CONTRACT START DATE | UDF_CONTRACT FINISH DATE | UDF_CONTRACT ITEM | UDF_SAVE ACT ID | UDF_BUDGETED LABOR UNIT | UDF_ACTUAL LABOR UNIT | Department | Constr. Area | PMT-Area | PMT-Schedule Org | PMT-Phase | PMT-Respons. | WBS Phase | WBS Discipline | WBS Type of Work | WBS Objects | Russia WBS Discipline (Russia) | Russia Construction Area | Russia WBS Phase | IMS | UPT | Russia WBS Objects | Subcontractor | UDF_CONTRACT INDICATOR | TB26 Semantics | TB26 Material Res Values | UDF_ELECTRICAL START | UDF_ELECTRICAL FINISH | UDF_CONTRACT FINISH DATE REV1 | UDF_CONTRACT START DATE REV1 | UDF_SELECT UPDATE PROGRESS | UDF_CHECK BASELINE | UDF_INDICATOR | UDF_CHECK RESOURCE DATES | UDF_Vendor Representatives | UDF_ELECTRICAL SEQUENCE | UDF_PENALIZED FINISH | Type of Work | Inquiry/Order No | Comments | 4 week lookahead | UDF_EXPECTED START | UDF_EXPECTED FINISH | UDF_CONTRACT DATE PENALIZED | UDF_PENALIZED START | Zeigen/n. Zeigen | UDF_Concrete |
| --- | --- | --- | --- | --- | --- | --- | --- | --- | --- | --- | --- | --- | --- | --- | --- | --- | --- | --- | --- | --- | --- | --- | --- | --- | --- | --- | --- | --- | --- | --- | --- | --- | --- | --- | --- | --- | --- | --- | --- | --- | --- | --- | --- | --- | --- | --- | --- | --- | --- | --- | --- | --- | --- | --- | --- | --- | --- | --- | --- | --- | --- | --- | --- | --- | --- | --- |
|  | E | **Electrical** |  |  | 2010-07-20 | 2012-08-15 |  |  |  |  |  |  |  |  |  |  |  |  |  |  |  |  |  |  |  |  |  |  |  |  |  |  |  |  |  |  |  |  |  |  |  |  |  |  |  |  |  |  |  |  |  |  |  |  |  |  |  |  |  |  |  |  |  |  |  |  |
| XC915104 |  | CA51 SR5104 - Installation Earthing Foundations_CIVIL |  | 36d | 2010-07-20 A | 2010-08-30 A | XC205104 SS, EE905104 (other project) | 100% |  |  |  |  |  |  |  | Grounding & Lightning [150 pcs]; Grounding & Lightning [1687.5 h] | 67,500 | 67,500 | 1687,50 | 2011-03-10 | 2011-09-20 | E-16-07-15 | XC915104 | 1687,5 | 1687,5 | 934 | 51 | 200 | 200 | C | LND | X | C | XE91 | 5104 | C | 51 | X | EA | LND | 5104 | MO11 |  |  |  |  |  |  |  |  |  |  |  |  |  |  |  |  |  |  |  |  |  |  |  |  |
| XE405104 |  | CA51 SR5104 - Install Cable Trays |  | 58d | 2011-05-31 A | 2011-08-13 A | P3E16S (other project), EE46510410 (other project), XN205104u | 100% |  | 2011-05-31 | 2011-08-06 |  |  | start on or after 2011-05-30 | TB26 - V - Construct-Winter partly * | Cable trays/conduits [1580 m]; Cable trays [4740 h] | 189,600 | 25,200 | 4740,00 | 2011-03-10 | 2011-05-31 | E-15-01-01 | XE405104 | 4740 | 630 | 934 | 51 | 200 | 200 | C | LND | X | E | XE40 | 5104 | E | 51 | X | EL | LND | 5104 | URMA | UDF_G4 | m | 2100 | 2011-05-25 | 2011-08-03 | 2011-09-15 | 2011-05-23 | 27.8. | x | UDF_G2 |  |  |  |  |  |  |  |  |  |  |  |  |  |  |
| XE705104 |  | CA51 SR5104 - Install Lighting & Small Power |  | 50d | 2011-08-23 A | 2011-10-19 | XP341610 FS+50d, P3E03S2 (other project) FF+20d, EE765104 (other project), XE405104 |  | 46d |  |  | 0d | 90d | finish on 2011-10-19 | TB26 - V - Construct-Winter partly * | Cable Pulling [600 m]; Lighting illuminates [110 pcs]; Lighting (iluminates) [1100 h]; Cable pulling [300 h] | 56,000 | 4,480 | 1400,00 | 2011-05-10 | 2012-01-31 | E-16-03-01 | XE705104 | 1400 | 0 | 934 | 51 | 200 | 200 | C | LND | X | E | XE70 | 5104 | E | 51 | X | EL | LND | 5104 | URMA |  |  |  |  |  | 2012-05-10 | 2011-08-15 | 27.8. |  | UDF_G2 | ok |  |  |  |  |  |  |  |  |  |  |  |  |  |
| XE915104 |  | CA51 SR5104 - Installation Earthing Foundations_E/I |  | 10d | 2011-08-27 | 2011-09-07 | XN205104u, XE405104, XJ425104 |  |  |  |  | 243d | 281.5d |  |  |  |  |  | 170 | 2011-03-10 | 2011-09-20 | E-16-07-15 | XE915104 | 0 | 0 | 934 | 51 | 200 | 200 | C | LND | X | E | XE91 | 5104 | E | 51 | X | EA | LND | 5104 | URMA |  |  |  |  |  | 2012-02-15 | 2011-05-23 |  |  | UDF_G2 |  |  |  |  |  |  |  |  |  |  |  |  |  |  |
| XE805104 |  | CA51 SR5104 - Install Heat Tracing |  | 90d | 2011-11-03 | 2012-04-20 | P3E19S (other project), XE800C00 SF, E3E1950 (other project), XR605104 FS-10d, XE705104 FF+12d |  |  |  |  | 58d | 0d |  | TB26 - V - Construct-Winter partly * | Electrical Heat Tracing [2600 m]; Electrical heat tracing [1300 h] | 52,000 |  | 1300,00 | 2011-06-20 | 2012-03-20 | E-16-04-01 | XE805104 | 1300 | 0 | 934 | 51 | 200 | 200 | C | LND | X | E | XE80 | 5104 | E | 51 | X | HT | LND | 5104 | URMA |  |  |  |  |  | 2012-06-30 | 2011-09-15 |  |  | UDF_G2 |  | 005 |  |  |  |  |  |  |  |  |  |  |  |  |
| XE505104 |  | CA51 SR5104 - Cable Pulling Electric |  | 60d | 2012-06-05 | 2012-08-15 | XE405104 FS+10d, XE500C01, XE505103 SS+6d, EE565104 (other project) |  |  |  |  | -71.5d | 0d |  | TB26 - V - Construct-Winter partly * | Cable Pulling [16900 m]; Cable pulling [8450 h] | 338,000 |  | 8450,00 | 2011-05-20 | 2012-02-10 | E-16-01-01 | XE505104 | 8450 | 0 | 934 | 51 | 200 | 200 | C | LND | X | E | XE50 | 5104 | E | 51 | X | EL | LND | 5104 | URMA |  | m | 17500 | 2011-08-20 | 2011-10-28 | 2012-07-01 | 2011-10-01 |  |  | UDF_G2 |  |  | XJ321321 |  |  |  |  |  |  |  |  |  |  |  |
|  | J | **Instrumentation** |  |  | 2011-07-04 | 2012-07-16 |  |  |  |  |  |  |  |  |  |  |  |  |  |  |  |  |  |  |  |  |  |  |  |  |  |  |  |  |  |  |  |  |  |  |  |  |  |  |  |  |  |  |  |  |  |  |  |  |  |  |  |  |  |  |  |  |  |  |  |  |
| XJ425104 |  | CA51 SR5104 - Install CableTrays Instrumentation |  | 47d | 2011-07-04 A | 2011-08-26 A | XN205104u, EJ46510410 (other project), XE405104 FF | 100% |  |  |  |  |  |  | TB26 - V - Construct-Winter partly * | Main cable trays [600 m]; Install Main Cable trays [1800 h] | 72,000 |  | 1800,00 | 2011-03-10 | 2011-05-31 | E-15-01-01 | XJ425104 | 1800 | 0 | 934 | 51 | 200 | 200 | C | LND | X | J | XJ42 | 5104 | J | 51 | X | IN | LND | 5104 | URMA |  | m | 1700 | 2011-05-25 | 2011-08-03 | 2011-09-15 | 2011-05-23 |  |  | UDF_G2 |  |  |  |  |  |  |  |  |  |  |  |  |  |  |
| XJ525104 |  | CA51 SR5104 - Pulling Instrument Cables |  | 50d | 2012-05-17 | 2012-07-16 | P3J17S1 (other project), XJ525103 SS, XE500C01, XJ425104, P3J17S (other project), XE405104, XJ321321 FS-20d |  |  |  |  | -22.5d | 0d |  | TB26 - V - Construct-Winter partly * | Multicore cables [4800 m]; Pull multicore cables [2400 h] | 96,000 |  | 2400,00 | 2011-03-10 | 2011-09-20 | E-17-04-15 | XJ525104 | 2400 | 0 | 934 | 51 | 200 | 200 | C | LND | X | J | XJ52 | 5104 | J | 51 | X | IN | LND | 5104 | URMA |  | m | 3500 | 2011-09-01 | 2011-10-28 | 2012-03-15 | 2011-08-10 |  |  | UDF_G2 |  |  |  | 2012-03-15 |  |  |  |  |  |  |  |  |  |  |
|  | W | **Painting** |  |  | 2012-01-23 | 2012-04-03 |  |  |  |  |  |  |  |  |  |  |  |  |  |  |  |  |  |  |  |  |  |  |  |  |  |  |  |  |  |  |  |  |  |  |  |  |  |  |  |  |  |  |  |  |  |  |  |  |  |  |  |  |  |  |  |  |  |  |  |  |
| XW505104 |  | CA51 SR5104 - Surf.Protection Piping |  | 60d | 2012-01-23 | 2012-04-03 | XR805104 FF+19d, XR205104 SS+20d |  |  |  |  | 304.5d |  |  |  | Piping painting [482 sqm]; Piping painting [1204 h] | 1,413.14 |  | 1204,00 |  |  |  | XW505104 | 1204 | 0 | 934 | 51 | 200 | 200 | C | LND | X | W | XW50 | 5104 | W | 51 | X | PA | LND | 5104 | VNZM |  |  |  |  |  |  |  |  |  |  |  |  |  |  |  |  |  |  |  |  |  |  |  |  |
|  | V | **Insulation** |  |  | 2011-11-22 | 2012-06-18 |  |  |  |  |  |  |  |  |  |  |  |  |  |  |  |  |  |  |  |  |  |  |  |  |  |  |  |  |  |  |  |  |  |  |  |  |  |  |  |  |  |  |  |  |  |  |  |  |  |  |  |  |  |  |  |  |  |  |  |  |
| XV505104 |  | CA51 SR5104 - Insulation Piping |  | 90.08d | 2011-11-22 | 2012-06-18 | XE805104 FF+20d, XE805104 SS+10d, XV500C00 SS |  |  |  |  | 58.92d | 50.42d |  | TB26 - T - Construct-Winter-3 (Dec/Jan/Feb free) * | Piping insulation [650 sqm]; Piping insulation [4875 h] | 5,368.74 |  | 4875,00 |  | 2012-04-30 | E-13-01 | XV505104 | 4875 | 0 | 934 | 51 | 200 | 200 | C | LND | X | V | XV50 | 5104 | V | 51 | X | INS | LND | 5104 | VNZM |  |  |  |  |  |  |  |  |  |  |  |  |  |  |  |  |  |  |  |  |  |  |  |  |
|  | 52 | **CA52 - Pipe Rack** |  |  | 2008-09-24 | 2012-07-30 |  |  |  |  |  |  |  |  |  |  |  |  |  |  |  |  |  |  |  |  |  |  |  |  |  |  |  |  |  |  |  |  |  |  |  |  |  |  |  |  |  |  |  |  |  |  |  |  |  |  |  |  |  |  |  |  |  |  |  |  |
| X0105210 |  | CA52 General - Construction Completion | milestone | 0d | 2012-07-27 | 2012-07-27 | XR405201, XE505201, XN205201u, XE915202, XE705201, XE805201, XJ525201 |  |  |  |  | -26.5d | 3.5d |  | TB26 - 2 - Manuf and Delivy |  |  |  |  |  |  |  | X0105210 | 0 | 0 | 934 | 52 | 200 | 200 | C | LND | X | 0B | X010 | 5200 | 0 | 52 | X | MC | LND | 5200 |  |  |  |  |  |  |  |  |  |  |  |  |  |  |  | XNK |  |  |  |  |  |  |  |  |  |
| X0105200 |  | CA52 General - Mechanical Completion | milestone | 0d | 2012-07-30 | 2012-07-30 | XE705201, XE505201, X0105210, XE915202, XV505201, XC605201 |  |  |  |  | 25d | 151.5d |  | TB26 - 2 - Manuf and Delivy |  |  |  |  |  |  |  | X0105200 | 0 | 0 | 934 | 52 | 200 | 200 | C | LND | X | 0B | X010 | 5200 | 0 | 52 | X | MC | LND | 5200 |  |  |  |  |  |  |  |  |  |  |  |  |  |  |  | XNK |  |  |  |  |  |  |  |  |  |
|  | C | **Civil Work** |  |  | 2008-09-24 | 2012-03-27 |  |  |  |  |  |  |  |  |  |  |  |  |  |  |  |  |  |  |  |  |  |  |  |  |  |  |  |  |  |  |  |  |  |  |  |  |  |  |  |  |  |  |  |  |  |  |  |  |  |  |  |  |  |  |  |  |  |  |  |  |
| XC115201 |  | CA52 SR5201 - Excavation&Surface Prep by U/I/O |  | 294d | 2008-09-24 A | 2009-09-30 A | XC111100 SS | 100% |  |  |  |  |  |  |  |  |  |  |  |  |  |  | XC115201 | 0 | 0 | 934 | 52 | 200 | 200 | C | UIO | X | C | XC11 | 5201 | C | 52 | X | CW | LND | 5201 | MO11 |  |  |  |  |  |  |  |  |  |  |  |  |  |  |  |  |  |  |  |  |  |  |  |  |
| XC11520105 |  | CA52 SR5201 - Excavation |  | 4d | 2010-03-16 A | 2010-03-19 A | XC115201 | 100% |  |  |  |  |  |  |  | Excavation [4000 cbm]; Excavation [2000 h] | 160,000 | 160,000 | 2000,00 |  |  |  | XC11520105 | 2000 | 2000 | 934 | 52 | 200 | 200 | C | MO02 | X | C | XC11 | 5201 | C | 10 | X | P | LND | 1010 | MO11 |  |  |  |  |  |  |  |  |  |  |  |  |  |  |  | 999 |  |  |  |  |  |  |  |  |
| XC11520110 |  | CA52 SR5201 - SubBase (Gravel/Geogrid) for Concrete |  | 17d | 2010-03-18 A | 2010-04-07 A | XC11520105 | 100% |  | 2010-03-18 | 2010-04-06 |  |  |  |  | Sub Base for Concrete/Paving&Roads (Gravel) [550 cbm]; Subbase for Concrete [550 h] | 55,000 | 15,000 | 550,00 |  |  |  | XC11520110 | 550 | 550 | 934 | 52 | 200 | 200 | C | MO02 | X | C | XC11 | 5201 | C | 10 | X | P | LND | 1010 | MO11 |  |  |  |  |  |  |  |  |  |  |  |  |  |  |  | 999 |  |  |  |  |  |  |  |  |
| XC155201 |  | CA52 SR5201 - Piling |  | 6d | 2010-10-23 A | 2010-10-29 A | XC11520105 FS+5d, XC115201, XC151100 FS+50d, EC155201 (other project) FS+12d, XC155501 FS+23d, F2910, XC11520110 FS+5d | 100% |  |  |  |  |  |  |  | Piles driven [150 pcs]; Piles driven [1125 h] | 45,000 | 45,000 | 1125,00 |  |  |  | XC155201 | 1125 | 1125 | 934 | 52 | 200 | 200 | C | MO02 | X | C | XC15 | 5201 | C | 52 | X | P | LND | 5201 | MO11 |  |  |  |  |  |  |  |  |  |  |  |  |  |  |  |  |  |  |  |  |  |  |  |  |
| XC205201 |  | CA52 SR5201 - Concrete Works |  | 67d | 2010-12-13 A | 2011-04-18 A | XC155201, EC28520105 (other project), P3C02D3 (other project) FF, EC285201 (other project) FS+10d | 100% |  |  |  |  |  | start on 2010-12-13 | TB26 - V - Construct-Winter partly * | Concrete works [470 cbm]; Concrete works [14100 h] | 6,984.38 |  | 14100,00 |  |  |  | XC205201 | 14100 | 14100 | 934 | 52 | 200 | 200 | C | CiC | X | C | XC20 | 5201 | C | 52 | X | mis | LND | 5201 | MO11 |  |  |  |  |  |  |  | x |  |  |  |  |  |  |  |  | Expected 8.4. | x |  |  |  |  |  |  |
| XC20520110 |  | CA52 SR5201 - Precast Concrete Elements |  | 36d | 2011-03-01 A | 2011-04-12 A | EC28520105 (other project) FS+89d, EC28520106 (other project), P3C02D3 (other project) FF | 100% |  |  |  |  |  |  |  |  |  |  |  |  |  |  | XC20520110 | 0 | 0 | 934 | 52 | 200 | 200 | C | CiC | X | C | XC20 | 5201 | C | 51 | X | pre | LND | 5104 | MO11 |  |  |  |  |  |  |  |  |  |  |  |  |  |  |  |  |  | x |  |  |  |  |  |  |
| XC20520115 |  | CA52 SR5201 - Erection Precast Elements |  | 26d | 2011-04-25 A | 2011-05-26 A | XC20520110 SS+24d, XC205201 FS-5d | 100% |  |  |  |  |  | start on or after 2011-04-25 |  | Precast Concrete Works [130 cbm]; Precast concrete works [325 h] | 13,000 | 13,000 | 325,00 |  |  |  | XC20520115 | 325 | 325 | 934 | 52 | 200 | 200 | C | CiC | X | C | XC20 | 5201 | C | 51 | X | mai | LND | 5104 | MO11 |  |  |  |  |  |  |  |  |  |  |  |  |  |  |  |  | MO-11: 7.5.11 compl. |  | 2011-04-18 | 2011-05-07 |  |  |  |  |
| XC20520120 |  | CA52 SR5201 - Erection Precast Elements finished | milestone | 0d | 2011-05-26 A | 2011-05-26 A | XC20520115 FF | 100% |  |  |  |  |  |  | TB26 - V - Construct-Winter partly * |  |  |  |  |  |  |  | XC20520120 | 0 | 0 | 934 | 52 | 200 | 200 | C | CiC | X | C | XC20 | 5201 | C | 31 | X | OB | LND | 3120 | MO11 |  |  |  |  |  |  |  |  |  |  |  |  |  | 2011-04-30 |  |  | MO-11: 7.5.11 compl. |  | 2011-05-07 | 2011-05-07 | P | 2011-04-30 | D |  |
| XC305201 |  | CA52 SR5201 - UG Installation (incl. Precast Manholes) |  | 40d | 2011-09-22 | 2011-11-09 | ER445201 (other project), XC300C00 SS, P3R02AS1 (other project), EC305201 (other project) FS+20d, XC310C00, P3R02BS (other project), XC205201 FF+20d, P3R02S1 (other project), P3R02S1 (other project) FF, XC300C00 FS+15d |  |  |  |  | 8d | 0d |  | TB26 - V - Construct-Winter partly * |  |  |  |  |  |  |  | XC305201 | 0 | 0 | 934 | 52 | 200 | 200 | C | CiC | X | C | XC30 | 5201 | C | 52 | X | mis | LND | 5201 |  |  |  |  |  |  |  |  |  |  |  |  |  |  |  |  |  |  |  |  |  |  |  |  | 1 |
| XC195201 |  | CA52 SR5201 - Backfill |  | 30d | 2011-10-15 | 2011-11-28 | XC20520115 FF, XC305201 SS+20d, XC915201 FF, XC305201 FF+10d |  |  |  |  | 125d | 0d |  | TB26 - T - Construct-Winter-3 (Dec/Jan/Feb free) * | Backfill & Compaction [2300 cbm]; Backfill & Compaction [3450 h] | 207,000 |  | 3450,00 |  |  |  | XC195201 | 3450 | 0 | 934 | 52 | 200 | 200 | C | CiC | X | C | XC19 | 5201 | C | 52 | X | mis | LND | 5201 |  |  |  |  |  |  |  |  |  |  |  |  |  |  |  |  |  |  |  |  |  |  |  |  |  |
| XC605201 |  | CA52 SR5201 - Paving |  | 20d | 2011-11-29 | 2012-03-27 | XC195201, XN205201l, XN205201u |  |  |  |  | 125d | 103d |  | TB26 - T - Construct-Winter-3 (Dec/Jan/Feb free) * | Gravel [430 sqm]; Gravel [21 h] | 2,032.49 |  | 21,00 |  |  |  | XC605201 | 21 | 0 | 934 | 52 | 200 | 200 | C | CiC | X | C | XC60 | 5201 | C | 52 | X | PV | LND | 5201 |  |  |  |  |  |  |  |  |  |  |  |  |  |  |  |  |  |  |  |  |  |  |  |  | 1 |

Notes:
- XE405104: UDF_PREDECESSOR: XN30, Piping 50%
- XE705104: UDF_PREDECESSOR: XE40, Civil 100%, HVAC ducts, Finishing works partly
- XE915104: UDF_PREDECESSOR: XN30, DEL XE40, DEL XE80, DEL XJ40, Civil 100%, Equipment 100%
- XE805104: UDF_PREDECESSOR: XR40, Piping 50% pressure tests
- XE505104: UDF_PREDECESSOR: XE40, XE50, DEL XE34
- XJ425104: UDF_PREDECESSOR: XE40, XJ32, Equipment 100%, Piping 50%
- XJ525104: UDF_PREDECESSOR: XE40, XJ32, XJ52
- XW505104: P3 Activity Log Info: Clarification Surface Protection during Prefab
- XC115201: P3 Activity Log Info: incl. Dewatering/Drainage
- XC155201: P3 Activity Log Info: 190 driven piles expected,20/d/machine
- XC205201: Current Status: 07.02.2011 (O. Siegel): Laut Aussage von MO11, die / Arbeiten wurden Unterbrochen. So im Januar keine / Ressourcen-Progress
- XC20520110: Current Status: 13.01.2011 (Oxana): Startdatum auf den 01.03.2011 geдndert / (Absprache mit Mostostroy am 11.01.2011). (durch Einfьgen von / Lag).
- XC305201: P3 Activity Log Info: Clarification Prefab Catch Basins/pulling pits

| ID | WBS | Activity | Type | Duration | Start | Finish | Predecessors | Complete | Remaining | Planned start | Planned finish | Total float | Free float | Constraint | Calendar | Resources | Cost | Actual cost | TB26 Ressource Budget | UDF_SAVE ACT ID | UDF_CHECK BASELINE | UDF_BUDGETED LABOR UNIT | UDF_ACTUAL LABOR UNIT | Department | Type of Work | Constr. Area | PMT-Area | PMT-Schedule Org | PMT-Phase | PMT-Respons. | Zeigen/n. Zeigen | WBS Phase | WBS Discipline | WBS Type of Work | WBS Objects | Russia WBS Discipline (Russia) | Russia Construction Area | Russia WBS Phase | IMS | UPT | Russia WBS Objects | UDF_CONTRACT ITEM | TB26 Semantics | UDF_SELECT UPDATE PROGRESS | UDF_CHECK RESOURCE DATES | Subcontractor | UDF_CONTRACT INDICATOR | UDF_COMMENTS_0827 | UDF_CONTRACT START DATE | UDF_CONTRACT FINISH DATE | UDF_PLANNED START | UDF_PLANNED FINISH | Comments | UDF_CONTRACT FINISH DATE REV1 | UDF_CONTRACT START DATE REV1 | UDF_INDICATOR | TB26 Material Res Values | UDF_ELECTRICAL START | UDF_ELECTRICAL FINISH | UDF_Vendor Representatives | UDF_CONTRACT FINISH DATE REV2 | UDF_CONTRACT START DATE REV2 |
| --- | --- | --- | --- | --- | --- | --- | --- | --- | --- | --- | --- | --- | --- | --- | --- | --- | --- | --- | --- | --- | --- | --- | --- | --- | --- | --- | --- | --- | --- | --- | --- | --- | --- | --- | --- | --- | --- | --- | --- | --- | --- | --- | --- | --- | --- | --- | --- | --- | --- | --- | --- | --- | --- | --- | --- | --- | --- | --- | --- | --- | --- | --- |
|  | N | **Structural Steel** |  |  | 2011-03-03 | 2011-10-24 |  |  |  |  |  |  |  |  |  |  |  |  |  |  |  |  |  |  |  |  |  |  |  |  |  |  |  |  |  |  |  |  |  |  |  |  |  |  |  |  |  |  |  |  |  |  |  |  |  |  |  |  |  |  |  |  |
| XN705201 |  | CA52 SR5201 - KMD Assy Drawings (first lots) | milestone | 0d | 2011-03-03 A | 2011-03-03 A |  | 100% |  |  |  |  |  | finish on 2011-03-03 |  |  |  |  | 22t | XN705201 | x | 0 | 0 | 934 | XNK | 52 | 200 | 200 | C | LND | KMD | X | N | XN05 | 5201 | N | 52 | X | PR | LND | 5201 |  |  |  |  |  |  |  |  |  |  |  |  |  |  |  |  |  |  |  |  |  |
| XN725201 |  | CA52 SR5201 - KMD Assy Drawings | milestone | 0d | 2011-03-10 A | 2011-03-10 A |  | 100% |  |  |  |  |  | finish on 2011-03-10 |  |  |  |  | 22t | XN725201 | x | 0 | 0 | 934 | XNK | 52 | 200 | 200 | C | LND | KMD | X | N | XN05 | 5201 | N | 52 | X | PR | LND | 5201 |  |  |  |  |  |  |  |  |  |  |  |  |  |  |  |  |  |  |  |  |  |
| XN715201 |  | CA52 SR5201 - Steel Deliveries (first lots) | milestone | 0d | 2011-03-11 A | 2011-03-11 A |  | 100% |  |  |  |  |  | finish on 2011-03-11 | TB26 - 3 - Construction Normal 7days * CA17 |  |  |  | 22t | XN715201 |  | 0 | 0 | 934 | XNK | 52 | 200 | 200 | C | LND | SD | X | N | XN06 | 5201 | N | 52 | X | PR | LND | 5201 |  |  |  |  |  |  |  |  |  |  |  |  |  |  |  |  |  |  |  |  |  |
| XN735201 |  | CA52 SR5201 - Steel Deliveries | milestone | 0d | 2011-03-27 A | 2011-03-27 A |  | 100% |  |  |  |  |  | finish on or after 2011-03-18 | TB26 - 3 - Construction Normal 7days * CA17 |  |  |  | 22t | XN735201 |  | 0 | 0 | 934 | XNK | 52 | 200 | 200 | C | LND | SD | X | N | XN06 | 5201 | N | 52 | X | PR | LND | 5201 |  |  |  |  |  |  |  |  |  |  |  |  |  |  |  |  |  |  |  |  |  |
| XN205201l |  | CA52 SR5201 - Installation Steel Structure |  | 18d | 2011-08-22 A | 2011-10-01 | P3N01EN (other project), XC20520120 FS+2d, XN715201 FS+10d, XN725201, P3N012D (other project) FS+10d, EN685201 (other project), XN735201 FS+10d, XN705201, XC915201 |  | 31d | 2011-08-22 | 2011-09-10 | -150d | 0d | start on or after 2011-08-02 | TB26 - V - Construct-Winter partly * | Piperacks, Main structures [7012.5 h]; Piperacks, Main Structures [165 t] | 280,500 | 31,875 | 3993,75 | XN205201l |  | 3993,75 | 0 | 934 | XNK | 52 | 200 | 200 | C | LND |  | X | N | XN20 | 5201 | N | 52 | X | PR | LND | 5201 | E-04-26 | t | 27.8. | x | SM |  |  |  |  |  |  |  |  |  |  |  |  |  |  |  |  |
| XN205201u |  | CA52 SR5201 - Install Railings, Gratings |  | 20d | 2011-10-01 | 2011-10-24 | XN725201, XN735201 FS+10d, XN715201 FS+10d, XN705201, XC20C000 FF, XN255201 FF, XN205201l FS-1d |  |  |  |  | -150d | 0d |  | TB26 - V - Construct-Winter partly * | Ladders & platforms [700 h]; Grating [1012.5 h]; Ladders & platforms [7 t]; Grating [270 sqm] | 68,500 |  | 4731,25 | XN205201u |  | 4731,25 | 0 | 934 | XNK | 52 | 200 | 200 | C | LND |  | X | N | XN20 | 5201 | N | 52 | X | PR | LND | 5201 | E-04-26 | t | 27.8. |  | SM |  |  |  |  |  |  |  |  |  |  |  |  |  |  |  |  |
| XN255201 |  | CA52 SR5201 - Installation fireproof castables |  | 5d | 2011-10-07 | 2011-10-12 | XN205201l FS+4d |  |  |  |  | -140d | 10d |  | TB26 - V - Construct-Winter partly * |  |  |  | 130 | XN255201 |  | 0 | 0 | 934 | XNK | 52 | 200 | 200 | C | LND |  | X | N | XN20 | 5201 | N | 52 | X | PR | LND | 5201 | E-04-26 | t | 27.8. |  | MO11 | UDF_G4 |  |  |  |  |  |  |  |  |  |  |  |  |  |  |  |
|  | H | **HVAC** |  |  |  |  |  |  |  |  |  |  |  |  |  |  |  |  |  |  |  |  |  |  |  |  |  |  |  |  |  |  |  |  |  |  |  |  |  |  |  |  |  |  |  |  |  |  |  |  |  |  |  |  |  |  |  |  |  |  |  |  |
|  | U | **Package Units** |  |  |  |  |  |  |  |  |  |  |  |  |  |  |  |  |  |  |  |  |  |  |  |  |  |  |  |  |  |  |  |  |  |  |  |  |  |  |  |  |  |  |  |  |  |  |  |  |  |  |  |  |  |  |  |  |  |  |  |  |
|  | B | **Mechanical - Stationary Equipment** |  |  |  |  |  |  |  |  |  |  |  |  |  |  |  |  |  |  |  |  |  |  |  |  |  |  |  |  |  |  |  |  |  |  |  |  |  |  |  |  |  |  |  |  |  |  |  |  |  |  |  |  |  |  |  |  |  |  |  |  |
|  | M | **Mechanical - Rotating Equipment** |  |  |  |  |  |  |  |  |  |  |  |  |  |  |  |  |  |  |  |  |  |  |  |  |  |  |  |  |  |  |  |  |  |  |  |  |  |  |  |  |  |  |  |  |  |  |  |  |  |  |  |  |  |  |  |  |  |  |  |  |
|  | R | **Piping** |  |  | 2011-10-01 | 2012-04-24 |  |  |  |  |  |  |  |  |  |  |  |  |  |  |  |  |  |  |  |  |  |  |  |  |  |  |  |  |  |  |  |  |  |  |  |  |  |  |  |  |  |  |  |  |  |  |  |  |  |  |  |  |  |  |  |  |
| XR205201 |  | CA52 SR5201 - Piping Prefabrication |  | 60d | 2011-10-01 | 2011-12-10 | P3R06CS1 (other project) FF+20d, ER495201 (other project) SS+18d, P3R06DS1 (other project) FS+10d, P3R06BS1 (other project) FS+10d, XR500C00 FS+15d |  |  |  |  | -26d | 0d | start on or after 2011-10-01 |  | A/G piping prefabrication [930 Fpi]; A/G Piping (Prefab) [3487.5 h] | 3,547.62 |  | 3487,50 | XR205201 |  | 3487,5 | 0 | 934 |  | 52 | 200 | 200 | C | LND |  | X | R | XR20 | 5201 | R | 52 | X | PRP | LND | 5201 |  |  | 27.8. |  |  |  | Start 1.10.11 |  |  |  |  |  |  |  |  |  |  |  |  |  |  |
| XR405201 |  | CA52 SR5201 - Piping Installation |  | 40d | 2011-12-26 | 2012-03-20 | ER475201 (other project) FS-20d, XN205201u, XR205201 SS+30d, XN205201l, XW505201 |  |  |  |  | -14d | 0d |  | TB26 - V - Construct-Winter partly * | A/G piping field installation [1150 Fpi]; Control & Shut-off valves [5 pcs]; A/G Piping (Field) [7187.5 h]; Install Control & Shut-off Valves [26.25 h] | 13,658.84 |  | 7213,75 | XR405201 |  | 7213,75 | 0 | 934 |  | 52 | 200 | 200 | C | LND |  | X | R | XR40 | 5201 | R | 52 | X | PI | LND | 5201 | E-06-03-10 |  |  |  |  |  |  | 2011-03-30 | 2011-09-30 | 2011-06-18 |  |  |  |  |  |  |  |  |  |  |  |
| XR605201 |  | CA52 SR5201 - Piping Pressure Tests |  | 20d | 2012-03-19 | 2012-04-12 | X0300020, XR605101 SS, XR405201 FF+18d |  |  |  |  | -14d | 0d |  | TB26 - T - Construct-Winter-3 (Dec/Jan/Feb free) * |  |  |  | 284 | XR605201 |  | 0 | 0 | 934 |  | 52 | 200 | 200 | C | LND |  | X | R | XR60 | 5201 | R | 52 | X | HY | LND | 5201 | E-06-03-10 |  |  |  |  |  |  | 2011-03-30 | 2011-09-30 |  |  |  |  |  |  |  |  |  |  |  |  |
| XR805201 |  | CA52 SR5201 - Piping Reinstatement |  | 15d | 2012-04-07 | 2012-04-24 | IMS-C-000360 FF, XR605201 FF+10d |  |  |  |  | 287.5d |  |  | TB26 - V - Construct-Winter partly * |  |  |  | 142 | XR805201 |  | 0 | 0 | 934 |  | 52 | 200 | 200 | C | LND |  | X | R | XR80 | 5201 | R | 52 | X | PI | LND | 5201 | E-06-03-10 |  |  |  |  |  |  | 2011-03-30 | 2011-09-30 |  | 2011-12-17 |  |  |  |  |  |  |  |  |  |  |
|  | E | **Electrical** |  |  | 2010-12-13 | 2012-07-27 |  |  |  |  |  |  |  |  |  |  |  |  |  |  |  |  |  |  |  |  |  |  |  |  |  |  |  |  |  |  |  |  |  |  |  |  |  |  |  |  |  |  |  |  |  |  |  |  |  |  |  |  |  |  |  |  |
| XC915201 |  | CA52 SR5201 - Installation Earthing Foundations - CIVIL |  | 116d | 2010-12-13 A | 2011-05-07 A | EE905201 (other project), XC205201 FF+5d | 100% |  |  |  |  |  |  |  | Grounding & Lightning [150 pcs]; Grounding & Lightning [1687.5 h] | 67,500 | 67,500 | 1687,50 | XC915201 |  | 1687,5 | 1687,5 | 934 |  | 52 | 200 | 200 | C | LND |  | X | C | XE91 | 5201 | C | 52 | X | EA | LND | 5201 | E-16-07-16 |  | x |  | MO11 |  |  | 2011-05-30 | 2011-10-20 |  |  | Expected 15.4. |  |  |  |  |  |  |  |  |  |
| XE915202 |  | CA52 SR5201 - Installation Earthing Foundations - E/I |  | 10d | 2011-10-25 | 2011-11-05 | XN205201l, XN205201u |  |  |  |  | 193d | 215.5d |  |  |  |  |  | 170 | XE915202 |  | 0 | 0 | 934 |  | 52 | 200 | 200 | C | LND |  | X | E | XE91 | 5201 | E | 52 | X | EA | LND | 5201 | E-16-07-16 |  | x |  | URMA |  |  | 2011-05-30 | 2011-10-20 |  |  | Expected 15.4. | 2012-04-15 | 2011-08-20 | UDF_G2 |  |  |  |  |  |  |
| XE405201 |  | CA52 SR5201 - Install Cable Trays |  | 15d | 2011-11-03 | 2011-11-21 | XE405102 SS, XN205201l, EE46520110 (other project), XE405101 SS, XN205201u FS+8d |  |  |  |  | 29d | 0d |  |  | Cable trays/conduits [730 m]; Cable trays [2190 h] | 87,600 |  | 2190,00 | XE405201 | x | 2190 | 0 | 934 |  | 52 | 200 | 200 | C | LND |  | X | E | XE40 | 5201 | E | 52 | X | EL | LND | 5201 | E-15-01-02 | m |  |  | URMA |  |  | 2011-05-30 | 2011-07-20 |  |  |  | 2011-11-10 | 2011-08-20 | UDF_G2 | 2400 | 2011-07-28 | 2011-10-05 |  |  |  |
| XE705201 |  | CA52 SR5201 - Install Lighting & Small Power |  | 30d | 2011-11-22 | 2012-02-01 | EE765201 (other project), XP341610 FS+50d, XE405201, XE705101 SS, P3E03S2 (other project), P3E09S (other project) |  |  |  |  | 108d | 130.5d |  | TB26 - V - Construct-Winter partly * | Cable Pulling [1500 m]; Lighting illuminates [110 pcs]; Lighting (iluminates) [1100 h]; Cable pulling [750 h] | 74,000 |  | 1850,00 | XE705201 |  | 1850 | 0 | 934 |  | 52 | 200 | 200 | C | LND |  | X | E | XE70 | 5201 | E | 52 | X | EL | LND | 5201 | E-16-03-01 |  |  |  | URMA |  |  | 2011-05-10 | 2012-01-31 |  |  |  | 2012-05-10 | 2011-08-15 | UDF_G2 |  |  |  |  |  |  |
| XE805201 |  | CA52 SR5201 - Install Heat Tracing |  | 60d | 2012-04-02 | 2012-06-13 | E3E1950 (other project), P3E19S (other project), XR605201 FS-10d |  |  |  |  | 15d | 0d |  | TB26 - V - Construct-Winter partly * | Electrical Heat Tracing [5400 m]; Electrical heat tracing [2700 h] | 108,000 |  | 2700,00 | XE805201 |  | 2700 | 0 | 934 |  | 52 | 200 | 200 | C | LND |  | X | E | XE80 | 5201 | E | 52 | X | HT | LND | 5201 | E-16-04-01 |  |  |  | URMA |  |  | 2011-06-20 | 2012-03-20 |  |  |  | 2012-06-30 | 2011-09-15 | UDF_G2 |  |  |  | 005 | 2012-04-15 | 2011-08-20 |
| XE505201 |  | CA52 SR5201 - Cable Pulling Electric |  | 60d | 2012-05-17 | 2012-07-27 | EE565201 (other project), XE500C01, P3E15BS (other project), XE505101 SS, XE405201 FS-10d, XE505102 SS, P3E15CS (other project), P3E15AS (other project) |  |  |  |  | -55.5d | 0d |  | TB26 - V - Construct-Winter partly * | Cable Pulling [16000 m]; Cable pulling [8000 h] | 320,000 |  | 8000,00 | XE505201 |  | 8000 | 0 | 934 |  | 52 | 200 | 200 | C | LND |  | X | E | XE50 | 5201 | E | 52 | X | EL | LND | 5201 | E-16-01-01 | m |  |  | URMA |  |  | 2011-05-20 | 2012-02-10 |  |  |  | 2012-07-01 | 2011-10-01 | UDF_G2 | 16500 | 2011-09-24 | 2012-03-15 |  |  |  |

Notes:
- XN715201: Scope: 09.02.2011: weight: 80 ton
- XN735201: Scope: 09.02.2011: weight: 100 ton
- XN205201l: Scope: 16.02.2011 (O.Siegel): die Liefermenge von 180 t / (Angaben vom 09.02.2011) wurden aufgeteilt auf lower und upper part.
- XN205201u: Scope: Grating 270m2 / Railing 7t
- XE915202: UDF_PREDECESSOR: XN30, DEL XE40, DEL XE80, DEL XJ40, Civil 100%, Equipment 100%
- XE405201: UDF_PREDECESSOR: XN30, Piping 50%
- XE705201: UDF_PREDECESSOR: XE40, Civil 100%
- XE805201: UDF_PREDECESSOR: XR40, Piping 50% pressure tests
- XE505201: UDF_PREDECESSOR: XE40, XE50, DEL XE34

| ID | WBS | Activity | Type | Duration | Start | Finish | Predecessors | Complete | Planned start | Planned finish | Total float | Free float | Constraint | Calendar | Resources | Cost | Actual cost | TB26 Ressource Budget | UDF_CONTRACT START DATE | UDF_CONTRACT FINISH DATE | UDF_CONTRACT ITEM | TB26 Semantics | TB26 Material Res Values | UDF_ELECTRICAL START | UDF_ELECTRICAL FINISH | UDF_CONTRACT FINISH DATE REV1 | UDF_CONTRACT START DATE REV1 | UDF_SAVE ACT ID | UDF_BUDGETED LABOR UNIT | UDF_ACTUAL LABOR UNIT | UDF_PREDECESSOR | UDF_INDICATOR | Department | Constr. Area | PMT-Area | PMT-Schedule Org | PMT-Phase | PMT-Respons. | WBS Phase | WBS Discipline | WBS Type of Work | WBS Objects | Russia WBS Discipline (Russia) | Russia Construction Area | Russia WBS Phase | IMS | UPT | Russia WBS Objects | Subcontractor | Type of Work | Zeigen/n. Zeigen | Inquiry/Order No | UDF_CONTRACT INDICATOR | UDF_CONTRACT DATE PENALIZED | UDF_PENALIZED START | UDF_PENALIZED FINISH | UDF_Concrete | UDF_SELECT UPDATE PROGRESS |
| --- | --- | --- | --- | --- | --- | --- | --- | --- | --- | --- | --- | --- | --- | --- | --- | --- | --- | --- | --- | --- | --- | --- | --- | --- | --- | --- | --- | --- | --- | --- | --- | --- | --- | --- | --- | --- | --- | --- | --- | --- | --- | --- | --- | --- | --- | --- | --- | --- | --- | --- | --- | --- | --- | --- | --- | --- | --- | --- |
|  | J | **Instrumentation** |  |  | 2011-11-22 | 2012-07-16 |  |  |  |  |  |  |  |  |  |  |  |  |  |  |  |  |  |  |  |  |  |  |  |  |  |  |  |  |  |  |  |  |  |  |  |  |  |  |  |  |  |  |  |  |  |  |  |  |  |  |  |  |
| XJ425201 |  | CA52 SR5201- Install CableTrays Instrumentation |  | 20d | 2011-11-22 | 2012-01-10 | XE405201, EJ46520110 (other project) |  |  |  | 15d | 80.5d |  | TB26 - V - Construct-Winter partly * | Main cable trays [250 m]; Install Main Cable trays [750 h] | 30,000 |  | 750,00 | 2011-05-30 | 2011-07-20 | E-15-01-02 | m | 740 | 2011-07-28 | 2011-10-05 | 2011-11-10 | 2011-08-20 | XJ425201 | 750 | 0 | XE40, XJ32, Equipment 100%, Piping 50% | UDF_G2 | 934 | 52 | 200 | 200 | C | LND | X | J | XJ42 | 5201 | J | 52 | X | IN | LND | 5201 | URMA |  |  |  |  |  |  |  |  |  |
| XJ525201 |  | CA52 SR5201 - Pulling Instrument Cables |  | 50d | 2012-05-17 | 2012-07-16 | XJ525101 SS, XE500C01, XJ525102 SS, XJ425201 |  |  |  | -65.5d | 2d |  | TB26 - V - Construct-Winter partly * | Multicore cables [4100 m]; Pull multicore cables [2050 h] | 82,000 |  | 2050,00 | 2011-05-30 | 2011-10-20 | E-17-04-16 | m | 3000 | 2011-10-06 | 2012-03-15 | 2012-03-30 | 2011-10-01 | XJ525201 | 2050 | 0 | XE40, XJ32, XJ52 | UDF_G2 | 934 | 52 | 200 | 200 | C | LND | X | J | XJ52 | 5201 | J | 52 | X | IN | LND | 5201 | URMA |  |  |  |  |  |  |  |  |  |
|  | S | **Safety & Environment** |  |  |  |  |  |  |  |  |  |  |  |  |  |  |  |  |  |  |  |  |  |  |  |  |  |  |  |  |  |  |  |  |  |  |  |  |  |  |  |  |  |  |  |  |  |  |  |  |  |  |  |  |  |  |  |  |
|  | W | **Painting** |  |  | 2011-10-13 | 2011-12-22 |  |  |  |  |  |  |  |  |  |  |  |  |  |  |  |  |  |  |  |  |  |  |  |  |  |  |  |  |  |  |  |  |  |  |  |  |  |  |  |  |  |  |  |  |  |  |  |  |  |  |  |  |
| XW505201 |  | CA52 SR5201 - Surf.Protection Piping |  | 60d | 2011-10-13 | 2011-12-22 | XR205201 FF+10d |  |  |  | -26d | 2d |  |  | Piping painting [357 sqm]; Piping painting [892 h] | 2,824.79 |  | 892,00 |  |  |  |  |  |  |  |  |  | XW505201 | 892 | 0 |  |  | 934 | 52 | 200 | 200 | C | LND | X | W | XW50 | 5201 | W | 52 | X | PA | LND | 5201 |  |  |  |  |  |  |  |  |  |  |
|  | V | **Insulation** |  |  | 2012-04-25 | 2012-07-30 |  |  |  |  |  |  |  |  |  |  |  |  |  |  |  |  |  |  |  |  |  |  |  |  |  |  |  |  |  |  |  |  |  |  |  |  |  |  |  |  |  |  |  |  |  |  |  |  |  |  |  |  |
| XV505201 |  | CA52 SR5201 - Insulation Piping |  | 80d | 2012-04-25 | 2012-07-30 | XE805201 SS+20d, XE805201 FF+20d |  |  |  | 22d | 0d |  | TB26 - V - Construct-Winter partly * | Piping insulation [350 sqm]; Piping insulation [2625 h] | 10,731.56 |  | 2625,00 |  | 2012-04-30 | E-13-01 |  |  |  |  |  |  | XV505201 | 2625 | 0 |  |  | 934 | 52 | 200 | 200 | C | LND | X | V | XV50 | 5201 | V | 52 | X | INS | LND | 5201 |  |  |  |  |  |  |  |  |  |  |
|  | 53 | **CA53 - Pipe Rack** |  |  | 2008-09-24 | 2012-07-30 |  |  |  |  |  |  |  |  |  |  |  |  |  |  |  |  |  |  |  |  |  |  |  |  |  |  |  |  |  |  |  |  |  |  |  |  |  |  |  |  |  |  |  |  |  |  |  |  |  |  |  |  |
|  | 0B | **General Activities** |  |  | 2012-07-30 | 2012-07-30 |  |  |  |  |  |  |  |  |  |  |  |  |  |  |  |  |  |  |  |  |  |  |  |  |  |  |  |  |  |  |  |  |  |  |  |  |  |  |  |  |  |  |  |  |  |  |  |  |  |  |  |  |
| X0105300 |  | CA53 General - Mechanical Completion | milestone | 0d | 2012-07-30 | 2012-07-30 | XC605301, XE505301 FF, X0105310, XE915301, XE705301, XJ525301, XV505301 FF |  |  |  | 25.5d | 152d |  | TB26 - 2 - Manuf and Delivy |  |  |  |  |  |  |  |  |  |  |  |  |  | X0105300 | 0 | 0 |  |  | 934 | 53 | 200 | 200 | C | LND | X | 0B | X010 | 5300 | 0 | 55 | X | MC | LND | 5500 |  | XNK | FL |  |  |  |  |  |  |  |
| X0105310 |  | CA53 General - Construction Completion | milestone | 0d | 2012-07-30 | 2012-07-30 | XN20530105, XJ525301, XC305301, XN205301, XR405301, XE805301, XE505301, XE705301, XE915301, XC605301, XC195301 |  |  |  | -29.5d | 0d |  | TB26 - 2 - Manuf and Delivy |  |  |  |  |  |  |  |  |  |  |  |  |  | X0105310 | 0 | 0 |  |  | 934 | 53 | 200 | 200 | C | LND | X | 0B | X010 | 5300 | 0 | 55 | X | MC | LND | 5500 |  | XNK | FL |  |  |  |  |  |  |  |
|  | 01 | **CA5301** |  |  | 2008-09-24 | 2012-07-30 |  |  |  |  |  |  |  |  |  |  |  |  |  |  |  |  |  |  |  |  |  |  |  |  |  |  |  |  |  |  |  |  |  |  |  |  |  |  |  |  |  |  |  |  |  |  |  |  |  |  |  |  |
|  | C | **Civil Work** |  |  | 2008-09-24 | 2011-11-22 |  |  |  |  |  |  |  |  |  |  |  |  |  |  |  |  |  |  |  |  |  |  |  |  |  |  |  |  |  |  |  |  |  |  |  |  |  |  |  |  |  |  |  |  |  |  |  |  |  |  |  |  |
| XC115301 |  | CA53 PR5301 - Excavation&Surface Prep by U/I/O |  | 294d | 2008-09-24 A | 2009-09-30 A | EC151410 (other project) SF | 100% |  |  |  |  |  |  |  |  |  |  |  |  |  |  |  |  |  |  |  | XC115301 | 0 | 0 |  |  | 934 | 53 | 200 | 200 | C | UIO | X | C | XC11 | 5301 | C | 53 | X | CW | LND | 5301 | MO11 |  | FL |  |  |  |  |  |  |  |
| XC11530105 |  | CA53 PR5301 - Excavation |  | 15d | 2011-05-03 A | 2011-05-20 A | XC11560110 FS+245d | 100% |  |  |  |  | start on or after 2011-05-02 |  | Excavation [4000 cbm]; Excavation [2000 h] | 160,000 | 160,000 | 2000,00 |  |  |  |  |  |  |  |  |  | XC11530105 | 2000 | 2000 |  |  | 934 | 53 | 200 | 200 | C | MO02 | X | C | XC11 | 5301 | C | 10 | X | P | LND | 1010 | MO11 |  |  | 999 |  |  |  |  |  |  |
| XC155301 |  | CA53 PR5301 - Piling |  | 10d | 2011-05-14 A | 2011-05-25 A | XC151410, XC151010, XC11530105 FS+10d, XC11530110 FS+2d, IMS-C-000010 FF, EC155301 (other project) FS+5d | 100% |  |  |  |  |  |  | Piles driven [172 pcs]; Piles driven [1290 h] | 51,600 | 51,600 | 1290,00 |  |  |  |  |  |  |  |  |  | XC155301 | 1290 | 1290 |  |  | 934 | 53 | 200 | 200 | C | MO02 | X | C | XC15 | 5301 | C | 53 | X | P | LND | 5301 | MO11 |  | FL |  |  |  |  |  |  |  |
| XC11530110 |  | CA53 SR5301 - SubBase (Gravel/Geogrid) for Concrete |  | 2d | 2011-05-28 A | 2011-05-31 A | XC11530105 | 100% | 2011-05-28 | 2011-05-30 |  |  |  |  | Sub Base for Concrete/Paving&Roads (Gravel) [850 cbm]; Subbase for Concrete [850 h] | 85,000 | 25,000 | 850,00 |  |  |  |  |  |  |  |  |  | XC11530110 | 850 | 850 |  |  | 934 | 53 | 200 | 200 | C | MO02 | X | C | XC11 | 5301 | C | 10 | X | P | LND | 1010 | MO11 |  |  | 999 |  |  |  |  |  |  |
| XC205301 |  | CA53 PR5301 - Concrete Works |  | 21d | 2011-05-30 A | 2011-06-23 A | XC20530110, EC28530105 (other project), XC155301 FS+10d, EC45530105 (other project), EC285301 (other project) FS+5d, EC28530106 (other project) | 100% |  |  |  |  |  | TB26 - V - Construct-Winter partly * | Concrete works [670 cbm]; Concrete works [20100 h] | 804,000 | 226,551.39 | 20100,00 |  |  |  |  |  |  |  |  |  | XC205301 | 20100 | 20100 |  |  | 934 | 53 | 200 | 200 | C | CiC | X | C | XC20 | 5301 | C | 53 | X | mis | LND | 5301 | MO11 |  | FL |  |  |  |  |  |  |  |
| XC20530105 |  | CA53 PR5301 - Precast Concrete Elements |  | 25d | 2011-06-01 A | 2011-06-30 A | P3C02D3 (other project) FF, EC28530105 (other project), EC28530106 (other project) | 100% |  |  |  |  |  |  |  |  |  |  |  |  |  |  |  |  |  |  |  | XC20530105 | 0 | 0 |  |  | 934 | 53 | 200 | 200 | C | CiC | X | C | XC20 | 5301 | C | 51 | X | pre | LND | 5104 | MO11 |  |  |  |  |  |  |  |  |  |
| XC20530110 |  | CA53 PR5301 - Erection Precast Elements |  | 38d | 2011-06-16 A | 2011-07-22 A | XC20530105 FS-10d | 100% | 2011-06-16 | 2011-07-29 |  |  |  | TB26 - V - Construct-Winter partly * | Precast Concrete Works [95 cbm]; Precast concrete works [238 h] | 9,500 | 3,300 | 238,00 |  |  |  |  |  |  |  |  |  | XC20530110 | 238 | 83 |  |  | 934 | 53 | 200 | 200 | C | CiC | X | C | XC20 | 5301 | C | 51 | X | mai | LND | 5104 | MO11 |  |  |  | UDF_G4 | P | 2011-06-25 | 2011-06-25 |  |  |
| XC195301 |  | CA53 PR5301 - Backfill |  | 30d | 2011-07-18 A | 2011-07-29 A | XC20530110 FF, XC915301 FF+10d, XC305301 FF+10d | 100% | 2011-08-15 | 2011-09-17 |  |  |  | TB26 - T - Construct-Winter-3 (Dec/Jan/Feb free) * | Backfill & Compaction [2300 cbm]; Backfill & Compaction [3450 h] | 207,000 | 207,000 | 3450,00 |  |  |  |  |  |  |  |  |  | XC195301 | 3450 | 0 |  |  | 934 | 53 | 200 | 200 | C | CiC | X | C | XC19 | 5301 | C | 53 | X | mis | LND | 5301 | MO11 |  | FL |  |  |  |  |  |  |  |
| XC305301 |  | CA53 PR5301 - UG Installation |  | 20d | 2011-10-03 | 2011-10-25 | P3R02BS (other project), ER445301 (other project), XC205301, XC300C00, P3R02AS1 (other project), EC305301 (other project) FS+20d, XC310C00, P3R02S1 (other project) |  |  |  | -1d | 45d | start on or after 2011-10-03 | TB26 - V - Construct-Winter partly * |  |  |  |  |  |  |  |  |  |  |  |  |  | XC305301 | 0 | 0 |  |  | 934 | 53 | 200 | 200 | C | CiC | X | C | XC30 | 5301 | C | 53 | X | mis | LND | 5301 |  |  | FL |  |  |  |  |  | 1 | 27.8. |
| XC605301 |  | CA53 PR5301 - Paving |  | 20d | 2011-10-24 | 2011-11-22 | XN205301, XC195301 |  |  |  | 101d | 125.5d |  | TB26 - T - Construct-Winter-3 (Dec/Jan/Feb free) * | Gravel | 824.08 |  | 0,00 |  |  |  |  |  |  |  |  |  | XC605301 | 0 | 0 |  |  | 934 | 53 | 200 | 200 | C | CiC | X | C | XC60 | 5301 | C | 53 | X | PV | LND | 5301 | MO11 |  | FL |  |  |  |  |  | 1 |  |

Notes:
- XW505201: P3 Activity Log Info: Clarification Surface Protection during Prefab
- XC115301: P3 Activity Log Info: incl. Dewatering/Drainage
- XC11530105: Current Status: 12.01.2011 (O. Siegel): Startdatum wurde am 11 und 12-Jan / 11 mit MO11 besprochen. Es wurde als Starttermin der 01-Mai-11 ausgesprochen. / nach unserem Plan ist es zu spдt, so dass der 01-Apr-11 als Starttermin / akzeptabel wдre.
- XC155301: P3 Activity Log Info: 108 driven piles expected,20/d/machine
- XC305301: P3 Activity Log Info: Clarification Prefab Catch Basins/pulling pits

| ID | WBS | Activity | Type | Duration | Start | Finish | Predecessors | Complete | Planned start | Planned finish | Total float | Free float | Constraint | Calendar | Resources | Cost | Actual cost | TB26 Ressource Budget | UDF_SAVE ACT ID | UDF_CHECK BASELINE | UDF_BUDGETED LABOR UNIT | UDF_ACTUAL LABOR UNIT | Department | Type of Work | Constr. Area | PMT-Area | PMT-Schedule Org | PMT-Phase | PMT-Respons. | Zeigen/n. Zeigen | WBS Phase | WBS Discipline | WBS Type of Work | WBS Objects | Russia WBS Discipline (Russia) | Russia Construction Area | Russia WBS Phase | IMS | UPT | Russia WBS Objects | UDF_CONTRACT ITEM | UDF_CONTRACT INDICATOR | TB26 Semantics | Subcontractor | UDF_CONTRACT START DATE | UDF_CONTRACT FINISH DATE | UDF_PLANNED START | UDF_PLANNED FINISH | TB26 Material Res Values | UDF_ELECTRICAL START | UDF_ELECTRICAL FINISH | UDF_CONTRACT FINISH DATE REV1 | UDF_CONTRACT START DATE REV1 | UDF_INDICATOR | UDF_COMMENTS_0827 | UDF_Vendor Representatives |
| --- | --- | --- | --- | --- | --- | --- | --- | --- | --- | --- | --- | --- | --- | --- | --- | --- | --- | --- | --- | --- | --- | --- | --- | --- | --- | --- | --- | --- | --- | --- | --- | --- | --- | --- | --- | --- | --- | --- | --- | --- | --- | --- | --- | --- | --- | --- | --- | --- | --- | --- | --- | --- | --- | --- | --- | --- |
|  | N | **Structural Steel** |  |  | 2011-05-30 | 2012-03-30 |  |  |  |  |  |  |  |  |  |  |  |  |  |  |  |  |  |  |  |  |  |  |  |  |  |  |  |  |  |  |  |  |  |  |  |  |  |  |  |  |  |  |  |  |  |  |  |  |  |  |
| XN705301 |  | CA53 SR5301/02/03 - KMD Assy Drawings | milestone | 0d | 2011-05-30 A | 2011-05-30 A |  | 100% |  |  |  |  | finish on 2011-05-30 |  |  |  |  | 22t | XN705301 | x | 0 | 0 | 934 | XNK | 53 | 200 | 200 | C | LND | KMD | X | N | XN05 | 5301 | N | 53 | X | PR | LND | 5301 |  |  |  |  |  |  |  |  |  |  |  |  |  |  |  |  |
| XN715301 |  | CA53 SR5301/02/03 - Steel Deliveries | milestone | 0d | 2011-09-05 | 2011-09-05 |  |  |  |  | 0d |  | finish on 2011-09-05 | TB26 - V - Construct-Winter partly * |  |  |  | 130 | XN715301 | x | 0 | 0 | 934 | XNK | 53 | 200 | 200 | C | LND | SD | X | N | XN06 | 5301 | N | 52 | X | PR | LND | 5301 | E-04-26 |  |  |  |  |  |  |  |  |  |  |  |  |  |  |  |
| XN205301 |  | CA53 SR5302/03 - Installation Steel Structure prior H-Lift |  | 30d | 2011-09-19 | 2011-10-22 | XC195301 FF+10d, XC20530110, XN715301 FS+11d, XC20C000 FF, P3N53IN (other project), XN705301 |  |  |  | 25d | 0d |  | TB26 - V - Construct-Winter partly * | Piperacks, Main Structures [68 t]; Ladders & platforms [5 t]; Grating [190 sqm]; Piperacks, Main structures [2890 h]; Ladders & platforms [500 h]; Grating [712.5 h] | 164,100 |  | 4102,50 | XN205301 | x | 4102,5 | 0 | 934 | XNK | 53 | 200 | 200 | C | LND | FL | X | N | XN20 | 5301 | N | 53 | X | PR | LND | 5301 | E-04-28 | UDF_G4 | t | ChSK |  |  |  |  |  |  |  |  |  |  |  |  |
| XN20530100 |  | CA53 SR5301 - Pre-assembling bridge (Installation after H-Lift) |  | 10d | 2012-02-07 | 2012-02-28 |  |  |  |  | -32d | 0d | as late as possible | TB26 - V - Construct-Winter partly * |  |  |  | 850,00 | XN20530105 |  | 850 | 0 | 934 | XNK | 53 | 200 | 200 | C | LND | FL | X | N | XN20 | 5301 | N | 53 | X | PR | LND | 5301 | E-04-29 |  |  | SM |  |  |  |  |  |  |  |  |  |  |  |  |
| XN20530105 |  | CA53 SR5301 - Installation Steel Structure after H-Lift |  | 10d | 2012-03-19 | 2012-03-30 | RF-22301, F-22304, F-21304, F-22301, C-22304, IMS-C-000140 FF, F-21301, C-21304, RF-21301, XN205301, XN20530100, XR405300 |  |  |  | -38d | 0d |  | TB26 - V - Construct-Winter partly * | Piperacks, Main Structures [20 t]; Piperacks, Main structures [850 h] | 34,000 |  | 850,00 | XN20530105 |  | 850 | 0 | 934 | XNK | 53 | 200 | 200 | C | LND | FL | X | N | XN20 | 5301 | N | 53 | X | PR | LND | 5301 | E-04-29 |  |  | SM |  |  |  |  |  |  |  |  |  |  |  |  |
|  | H | **HVAC** |  |  |  |  |  |  |  |  |  |  |  |  |  |  |  |  |  |  |  |  |  |  |  |  |  |  |  |  |  |  |  |  |  |  |  |  |  |  |  |  |  |  |  |  |  |  |  |  |  |  |  |  |  |  |
|  | U | **Package Units** |  |  |  |  |  |  |  |  |  |  |  |  |  |  |  |  |  |  |  |  |  |  |  |  |  |  |  |  |  |  |  |  |  |  |  |  |  |  |  |  |  |  |  |  |  |  |  |  |  |  |  |  |  |  |
|  | B | **Mechanical - Stationary Equipment** |  |  |  |  |  |  |  |  |  |  |  |  |  |  |  |  |  |  |  |  |  |  |  |  |  |  |  |  |  |  |  |  |  |  |  |  |  |  |  |  |  |  |  |  |  |  |  |  |  |  |  |  |  |  |
|  | M | **Mechanical - Rotating Equipment** |  |  |  |  |  |  |  |  |  |  |  |  |  |  |  |  |  |  |  |  |  |  |  |  |  |  |  |  |  |  |  |  |  |  |  |  |  |  |  |  |  |  |  |  |  |  |  |  |  |  |  |  |  |  |
|  | R | **Piping** |  |  | 2011-09-30 | 2012-05-12 |  |  |  |  |  |  |  |  |  |  |  |  |  |  |  |  |  |  |  |  |  |  |  |  |  |  |  |  |  |  |  |  |  |  |  |  |  |  |  |  |  |  |  |  |  |  |  |  |  |  |
| XR205301 |  | CA53 PR5301 - Piping Prefabrication |  | 30d | 2011-09-30 | 2011-11-03 | XN205301 SS-10d, ER495301 (other project), XR500C00 FS+15d |  |  |  | 109d | 0d | as late as possible |  | A/G piping prefabrication [1170 Fpi]; A/G Piping (Prefab) [4387.5 h] | 92.39 |  | 4387,50 | XR205301 |  | 4387,5 | 0 | 934 |  | 53 | 200 | 200 | C | LND | FL | X | R | XR20 | 5301 | R | 53 | X | PRP | LND | 5301 |  |  |  |  |  |  |  |  |  |  |  |  |  |  |  |  |
| XR405301 |  | CA53 PR5301 - Piping Installation |  | 30d | 2011-10-24 | 2011-11-28 | XR205301 FF+10d, ER475301 (other project) FS-20d, XN205301, XR205301 SS+20d |  |  |  | 109d | 113d |  |  | A/G piping field installation [1450 Fpi]; A/G Piping (Field) [9062.5 h] | 325.2 |  | 9062,50 | XR405301 |  | 9062,5 | 0 | 934 |  | 53 | 200 | 200 | C | LND | FL | X | R | XR40 | 5301 | R | 53 | X | PI | LND | 5301 | E-06-03-11 |  |  |  | 2011-06-15 | 2011-10-30 | 2011-08-26 |  |  |  |  |  |  |  |  |  |
| XR205300 |  | CA53 PR5301 - Piping Prefabrication (for bridge) |  | 15d | 2012-02-10 | 2012-02-28 |  |  |  |  | -64d | 0d | as late as possible |  |  |  |  | 4387,50 | XR205301 |  | 4387,5 | 0 | 934 |  | 53 | 200 | 200 | C | LND | FL | X | R | XR20 | 5301 | R | 53 | X | PRP | LND | 5301 |  |  |  |  |  |  |  |  |  |  |  |  |  |  |  |  |
| XR405300 |  | CA53 PR5301 - Piping Installation (on pre-assembled bridge) |  | 15d | 2012-02-29 | 2012-03-17 | XR205300, XN20530100 |  |  |  | -64d | 0d | as late as possible |  |  |  |  | 9062,50 | XR405301 |  | 9062,5 | 0 | 934 |  | 53 | 200 | 200 | C | LND | FL | X | R | XR40 | 5301 | R | 53 | X | PI | LND | 5301 | E-06-03-11 |  |  |  | 2011-06-15 | 2011-10-30 | 2011-08-26 |  |  |  |  |  |  |  |  |  |
| XR605301 |  | CA53 PR5301 - Piping Pressure Tests |  | 30d | 2012-03-31 | 2012-05-05 | X0300020, XR600C00 SS, XR405301 FF+15d, XN20530105 |  |  |  | -4d | 0d |  |  |  |  |  | 379 | XR605301 |  | 0 | 0 | 934 |  | 53 | 200 | 200 | C | LND | FL | X | R | XR60 | 5301 | R | 53 | X | HY | LND | 5301 | E-06-03-11 |  |  |  | 2011-06-15 | 2011-10-30 |  |  |  |  |  |  |  |  |  |  |
| XR805301 |  | CA53 PR5301 - Piping Reinstatement |  | 10d | 2012-04-30 | 2012-05-12 | XR605301 FF+5d, IMS-C-000360 FF |  |  |  | 25d | 0d |  |  |  |  |  | 189 | XR805301 |  | 0 | 0 | 934 |  | 53 | 200 | 200 | C | LND | FL | X | R | XR80 | 5301 | R | 53 | X | PI | LND | 5301 | E-06-03-11 |  |  |  | 2011-06-15 | 2011-10-30 |  | 2012-01-18 |  |  |  |  |  |  |  |  |
|  | E | **Electrical** |  |  | 2011-06-01 | 2012-07-30 |  |  |  |  |  |  |  |  |  |  |  |  |  |  |  |  |  |  |  |  |  |  |  |  |  |  |  |  |  |  |  |  |  |  |  |  |  |  |  |  |  |  |  |  |  |  |  |  |  |  |
| XC915301 |  | CA53 PR5301 - Installation Earthing Foundations_CIVIL |  | 19d | 2011-06-01 A | 2011-06-24 A | EE905301 (other project), XC205301 FF, IMS-C-000230 FF | 100% | 2011-06-01 | 2011-06-23 |  |  |  | TB26 - V - Construct-Winter partly * | Grounding & Lightning [100 pcs]; Grounding & Lightning [1125 h] | 45,000 | 40,500 | 1125,00 | XC915301 |  | 1125 | 1125 | 934 |  | 53 | 200 | 200 | C | LND | FL | X | C | XE91 | 5301 | C | 53 | X | EA | LND | 5301 |  |  |  | MO11 |  |  |  |  |  |  |  |  |  |  |  |  |
| XE405300 |  | CA53 PR5301 - Install Cable Trays Electric |  | 30d | 2011-11-22 | 2012-02-01 | XN205301 FS+19d, EE46530110 (other project) FS+130d |  |  |  | 25d | 0d |  | TB26 - V - Construct-Winter partly * | Cable trays/conduits; Cable trays |  |  | 1020,00 | XE405301 | x | 1020 | 0 | 934 |  | 53 | 200 | 200 | C | LND | FL | X | E | XE40 | 5301 | E | 53 | X | EL | LND | 5301 | E-15-01-03 |  | m | URMA | 2011-08-15 | 2011-09-30 |  |  | 1500 | 2011-08-30 | 2011-10-26 | 2012-04-30 | 2012-01-20 | UDF_G2 |  |  |
| XE915301 |  | CA53 PR5301 - Installation Earthing Foundations_E/I |  | 20d | 2011-11-23 | 2012-01-11 | XN205301 FS+20d |  |  |  | 117d | 141.5d |  | TB26 - V - Construct-Winter partly * |  |  |  | 115 | XE915301 |  | 0 | 0 | 934 |  | 53 | 200 | 200 | C | LND | FL | X | E | XE91 | 5301 | E | 53 | X | EA | LND | 5301 |  |  |  | URMA |  |  |  |  |  |  |  | 2012-04-30 | 2012-01-20 | UDF_G2 |  |  |
| XE405301 |  | CA53 PR5301 - Install Cable Trays Electric (after H-Lift) |  | 30d | 2012-04-02 | 2012-05-07 | XN205301 FS+19d, XN20530105, EE46530110 (other project) FS+130d |  |  |  | -38d | 0d |  | TB26 - V - Construct-Winter partly * | Cable trays/conduits [340 m]; Cable trays [1020 h] | 40,800 |  | 1020,00 | XE405301 | x | 1020 | 0 | 934 |  | 53 | 200 | 200 | C | LND | FL | X | E | XE40 | 5301 | E | 53 | X | EL | LND | 5301 | E-15-01-03 |  | m | URMA | 2011-08-15 | 2011-09-30 |  |  | 1500 | 2011-08-30 | 2011-10-26 | 2012-04-30 | 2012-01-20 | UDF_G2 | EARLIER NEEDED |  |
| XE805301 |  | CA53 PR5301 - Install Heat Tracing |  | 60d | 2012-04-24 | 2012-07-05 | XR605301 FS-10d, XW505301 FF+10d, XE705301 FF+6d, E3E1950 (other project) |  |  |  | -4d | 0d |  | TB26 - V - Construct-Winter partly * | Electrical Heat Tracing [1600 m]; Electrical heat tracing [800 h] | 32,000 |  | 800,00 | XE805301 |  | 800 | 0 | 934 |  | 53 | 200 | 200 | C | LND | FL | X | E | XE80 | 5301 | E | 53 | X | HT | LND | 5301 | E-16-04-01 |  |  | URMA | 2011-06-20 | 2012-03-20 |  |  |  |  |  | 2012-06-30 | 2011-09-15 | UDF_G2 |  | 005 |
| XE705301 |  | CA53 PR5301 - Install Lighting & Small Power |  | 30d | 2012-04-25 | 2012-05-31 | XP341610 FS+50d, XE405301 FS-10d, XN205301, EE765301 (other project), XE405300 FS-10d |  |  |  | 19d | 23d |  | TB26 - V - Construct-Winter partly * | Cable Pulling [600 m]; Lighting illuminates [110 pcs]; Lighting (iluminates) [1100 h]; Cable pulling [300 h] | 56,000 |  | 1400,00 | XE705301 |  | 1400 | 0 | 934 |  | 53 | 200 | 200 | C | LND | FL | X | E | XE70 | 5301 | E | 53 | X | EL | LND | 5301 | E-16-03-01 |  |  | URMA | 2011-05-10 | 2012-01-31 |  |  |  |  |  | 2012-05-10 | 2011-08-15 | UDF_G2 |  |  |
| XE505301 |  | CA53 PR5301 - Cable Pulling Electric |  | 40d | 2012-06-13 | 2012-07-30 | XE405301, XE500C01, EE565301 (other project), XE505104 SS+6d, XE405300 |  |  |  | -67.5d | 0d |  | TB26 - V - Construct-Winter partly * | Cable Pulling [8200 m]; Cable pulling [4100 h] | 164,000 |  | 4100,00 | XE505301 |  | 4100 | 0 | 934 |  | 53 | 200 | 200 | C | LND | FL | X | E | XE50 | 5301 | E | 53 | X | EL | LND | 5301 | E-16-01-01 |  | m | URMA | 2011-05-20 | 2012-02-10 |  |  | 8500 | 2011-11-30 | 2012-04-21 | 2012-07-01 | 2011-10-01 | UDF_G2 |  |  |

Notes:
- XN715301: Scope: 09.02.2011: weight: 100 ton
- XN20530100: Scope: 16.02.2011 (O.Siegel): die Liefermenge von 100 t / (Angaben vom 09.02.2011) wurden aufgeteilt auf lower (80 t) und upper (20 / t) part.
- XN20530105: Scope: 16.02.2011 (O.Siegel): die Liefermenge von 100 t / (Angaben vom 09.02.2011) wurden aufgeteilt auf lower (80 t) und upper (20 / t) part.
- XE405300: UDF_PREDECESSOR: XN30, Piping 50%
- XE915301: UDF_PREDECESSOR: XN30, DEL XE40, DEL XE80, DEL XJ40, Civil 100%, Equipment 100%
- XE405301: UDF_PREDECESSOR: XN30, Piping 50%
- XE805301: UDF_PREDECESSOR: XR40, Piping 50% pressure tests
- XE705301: UDF_PREDECESSOR: XE40, Civil 100%, HVAC ducts, Finishing works partly
- XE505301: UDF_PREDECESSOR: XE40, XE50, DEL XE34

| ID | WBS | Activity | Type | Duration | Start | Finish | Predecessors | Complete | Planned start | Planned finish | Total float | Free float | Constraint | Calendar | Resources | Cost | Actual cost | TB26 Ressource Budget | UDF_CONTRACT START DATE | UDF_CONTRACT FINISH DATE | UDF_CONTRACT ITEM | TB26 Semantics | TB26 Material Res Values | UDF_ELECTRICAL START | UDF_ELECTRICAL FINISH | UDF_CONTRACT FINISH DATE REV1 | UDF_CONTRACT START DATE REV1 | UDF_SAVE ACT ID | UDF_CHECK BASELINE | UDF_BUDGETED LABOR UNIT | UDF_ACTUAL LABOR UNIT | UDF_PREDECESSOR | UDF_INDICATOR | Department | Constr. Area | PMT-Area | PMT-Schedule Org | PMT-Phase | PMT-Respons. | Zeigen/n. Zeigen | WBS Phase | WBS Discipline | WBS Type of Work | WBS Objects | Russia WBS Discipline (Russia) | Russia Construction Area | Russia WBS Phase | IMS | UPT | Russia WBS Objects | Subcontractor | Type of Work | Inquiry/Order No | UDF_Concrete | UDF_SELECT UPDATE PROGRESS | Comments | 4 week lookahead | UDF_CONTRACT INDICATOR | UDF_CHECK CRITICAL PATH |
| --- | --- | --- | --- | --- | --- | --- | --- | --- | --- | --- | --- | --- | --- | --- | --- | --- | --- | --- | --- | --- | --- | --- | --- | --- | --- | --- | --- | --- | --- | --- | --- | --- | --- | --- | --- | --- | --- | --- | --- | --- | --- | --- | --- | --- | --- | --- | --- | --- | --- | --- | --- | --- | --- | --- | --- | --- | --- | --- | --- |
|  | J | **Instrumentation** |  |  | 2011-12-26 | 2012-07-04 |  |  |  |  |  |  |  |  |  |  |  |  |  |  |  |  |  |  |  |  |  |  |  |  |  |  |  |  |  |  |  |  |  |  |  |  |  |  |  |  |  |  |  |  |  |  |  |  |  |  |  |  |  |
| XJ425301 |  | CA53 PR5301 - Install CableTrays Instrumentation |  | 30d | 2011-12-26 | 2012-03-05 | EJ46530110 (other project), XE405300 FS-15d |  |  |  | 53d | 55.5d |  | TB26 - V - Construct-Winter partly * | Main cable trays [200 m]; Install Main Cable trays [600 h] | 24,000 |  | 600,00 | 2011-08-15 | 2011-09-30 | E-15-01-03 | m | 600 | 2011-08-30 | 2011-10-26 | 2012-04-30 | 2012-01-20 | XJ425301 | x | 600 | 0 | XE40, XJ32, Equipment 100%, Piping 50% | UDF_G2 | 934 | 53 | 200 | 200 | C | LND | FL | X | J | XJ42 | 5301 | J | 53 | X | IN | LND | 5301 | URMA |  |  |  |  |  |  |  |  |
| XJ525301 |  | CA53 PR5301 - Pulling Instrument Cables |  | 40d | 2012-05-17 | 2012-07-04 | XJ425301, XE500C01, XE405300, XJ525104 SS |  |  |  | -2.5d | 10d |  | TB26 - V - Construct-Winter partly * | Multicore cables [1200 m]; Pull multicore cables [600 h] | 24,000 |  | 600,00 |  |  |  | m | 900 | 2011-11-30 | 2012-04-21 |  |  | XJ525301 |  | 600 | 0 | XE40, XJ32, XJ52 | UDF_G2 | 934 | 53 | 200 | 200 | C | LND | FL | X | J | XJ52 | 5301 | J | 53 | X | IN | LND | 5301 | URMA |  |  |  |  |  |  |  |  |
|  | S | **Safety & Environment** |  |  |  |  |  |  |  |  |  |  |  |  |  |  |  |  |  |  |  |  |  |  |  |  |  |  |  |  |  |  |  |  |  |  |  |  |  |  |  |  |  |  |  |  |  |  |  |  |  |  |  |  |  |  |  |  |  |
|  | W | **Painting** |  |  | 2012-04-13 | 2012-05-19 |  |  |  |  |  |  |  |  |  |  |  |  |  |  |  |  |  |  |  |  |  |  |  |  |  |  |  |  |  |  |  |  |  |  |  |  |  |  |  |  |  |  |  |  |  |  |  |  |  |  |  |  |  |
| XW505301 |  | CA53 PR5301 - Surf.Protection Piping |  | 30d | 2012-04-13 | 2012-05-19 | XR805301 FF+6d, XR205301 SS |  |  |  | 25d | 29d |  |  | Piping painting [477 sqm]; Piping painting [1193 h] | 753.87 |  | 1193,00 |  |  |  |  |  |  |  |  |  | XW505301 |  | 1193 | 0 |  |  | 934 | 53 | 200 | 200 | C | LND | FL | X | W | XW50 | 5301 | W | 53 | X | PA | LND | 5301 |  |  |  |  |  |  |  |  |  |
|  | V | **Insulation** |  |  | 2012-05-19 | 2012-07-28 |  |  |  |  |  |  |  |  |  |  |  |  |  |  |  |  |  |  |  |  |  |  |  |  |  |  |  |  |  |  |  |  |  |  |  |  |  |  |  |  |  |  |  |  |  |  |  |  |  |  |  |  |  |
| XV505301 |  | CA53 PR5301 - Insulation Piping |  | 60d | 2012-05-19 | 2012-07-28 | XE805301 SS+20d, XE805301 FF+20d |  |  |  | 23d | 0.5d |  | TB26 - V - Construct-Winter partly * | Piping insulation [500 sqm]; Piping insulation [3750 h] | 2,861.75 |  | 3750,00 |  | 2012-04-30 | E-13-01 |  |  |  |  |  |  | XV505301 |  | 3750 | 0 |  |  | 934 | 53 | 200 | 200 | C | LND | FL | X | V | XV50 | 5301 | V | 53 | X | INS | LND | 5301 |  |  |  |  |  |  |  |  |  |
|  | 54 | **CA54 - Pipe Rack** |  |  | 2008-09-24 | 2012-09-12 |  |  |  |  |  |  |  |  |  |  |  |  |  |  |  |  |  |  |  |  |  |  |  |  |  |  |  |  |  |  |  |  |  |  |  |  |  |  |  |  |  |  |  |  |  |  |  |  |  |  |  |  |  |
|  | 0B | **General Activities** |  |  | 2012-09-12 | 2012-09-12 |  |  |  |  |  |  |  |  |  |  |  |  |  |  |  |  |  |  |  |  |  |  |  |  |  |  |  |  |  |  |  |  |  |  |  |  |  |  |  |  |  |  |  |  |  |  |  |  |  |  |  |  |  |
| X0105400 |  | CA54 General - Mechanical Completion | milestone | 0d | 2012-09-12 | 2012-09-12 | X0105410, XC605401, XV505401, XE505401, XE505402, XE705401, XE705402, XC605402, XV505402 |  |  |  | -18.5d | 108d |  | TB26 - 2 - Manuf and Delivy |  |  |  |  |  |  |  |  |  |  |  |  |  | X0105400 |  | 0 | 0 |  |  | 934 | 54 | 200 | 200 | C | LND |  | X | 0B | X010 | 5400 | 0 | 54 | X | MC | LND | 5400 |  | XNK |  |  |  |  |  |  |  |
| X0105410 |  | CA54 General - Construction Completion | milestone | 0d | 2012-09-12 | 2012-09-12 | XC305401, XC195401, XN605401, XC605401, XE705401, XJ525401, XN205401, XE505401, XE705402, XN605402, XN405401, XN405402, XR405401 |  |  |  | -73.5d | 0d |  | TB26 - 2 - Manuf and Delivy |  |  |  |  |  |  |  |  |  |  |  |  |  | X0105410 |  | 0 | 0 |  |  | 934 | 54 | 200 | 200 | C | LND |  | X | 0B | X010 | 5400 | 0 | 54 | X | MC | LND | 5400 |  | XNK |  |  |  |  |  |  |  |
|  | 01 | **CA5401** |  |  | 2008-09-24 | 2012-09-12 |  |  |  |  |  |  |  |  |  |  |  |  |  |  |  |  |  |  |  |  |  |  |  |  |  |  |  |  |  |  |  |  |  |  |  |  |  |  |  |  |  |  |  |  |  |  |  |  |  |  |  |  |  |
|  | C | **Civil Work** |  |  | 2008-09-24 | 2012-03-14 |  |  |  |  |  |  |  |  |  |  |  |  |  |  |  |  |  |  |  |  |  |  |  |  |  |  |  |  |  |  |  |  |  |  |  |  |  |  |  |  |  |  |  |  |  |  |  |  |  |  |  |  |  |
| XC115401 |  | CA54 SR5401 - Excavation&Surface Prep by U/I/O |  | 294d | 2008-09-24 A | 2009-09-30 A | XC111600 SS | 100% |  |  |  |  |  |  |  |  |  |  |  |  |  |  |  |  |  |  |  | XC115401 |  | 0 | 0 |  |  | 934 | 54 | 200 | 200 | C | UIO |  | X | C | XC11 | 5401 | C | 54 | X | CW | LND | 5401 | MO11 |  |  |  |  |  |  |  |  |
| XC11540105 |  | CA54 SR5401 - Excavation |  | 5d | 2010-04-26 A | 2010-04-30 A | XC11160005 FF+3d, XC11160005 SS | 100% |  |  |  |  |  |  | Excavation [4000 cbm]; Excavation [2000 h] | 160,000 | 160,000 | 2000,00 |  |  |  |  |  |  |  |  |  | XC11540105 |  | 2000 | 2000 |  |  | 934 | 54 | 200 | 200 | C | MO02 |  | X | C | XC11 | 5401 | C | 10 | X | P | LND | 1010 | MO11 |  | 999 |  |  |  |  |  |  |
| XC11540110 |  | CA54 SR5401 - SubBase (Gravel/Geogrid) for Concrete |  | 12d | 2010-05-10 A | 2010-05-24 A | XC11540105 FS+6d | 100% | 2010-05-10 | 2010-05-22 |  |  |  |  | Sub Base for Concrete/Paving&Roads (Gravel) [500 cbm]; Subbase for Concrete [500 h] | 50,000 | 15,000 | 500,00 |  |  |  |  |  |  |  |  |  | XC11540110 |  | 500 | 500 |  |  | 934 | 54 | 200 | 200 | C | MO02 |  | X | C | XC11 | 5401 | C | 10 | X | P | LND | 1010 | MO11 |  | 999 |  |  |  |  |  |  |
| XC155401 |  | CA54 SR5401 - Piling |  | 35d | 2010-05-24 A | 2010-07-02 A | XC115401, XC11540105 FS+8d, F2910, XC11540110, EC155401 (other project) FS+6d | 100% |  |  |  |  |  |  | Piles driven [80 pcs]; Piles driven [600 h] | 24,000 | 24,000 | 600,00 |  |  |  |  |  |  |  |  |  | XC155401 |  | 600 | 600 |  |  | 934 | 54 | 200 | 200 | C | MO02 |  | X | C | XC15 | 5401 | C | 54 | X | P | LND | 5401 | MO11 |  |  |  |  |  |  |  |  |
| XC205401 |  | CA54 SR5401 - Concrete Works |  | 59d | 2010-09-21 A | 2010-12-15 A | XC155401 FS+5d, EC285401 (other project) FS+10d, EC45540105 (other project), P3C02D2 (other project) FS+40d | 100% |  |  |  |  |  | TB26 - V - Construct-Winter partly * | Concrete works [190 cbm]; Concrete works [5700 h] | 228,000 | 228,000 | 5700,00 |  |  |  |  |  |  |  |  |  | XC205401 |  | 5700 | 5700 |  |  | 934 | 54 | 200 | 200 | C | MO04 |  | X | C | XC20 | 5401 | C | 54 | X | mis | LND | 5401 | MO11 |  |  |  |  |  |  |  |  |
| XC305401 |  | CA54 SR5401 - UG Installation (incl. Precast Manholes) |  | 40d | 2011-09-12 | 2011-10-27 | XC300C00, P3R02AS1 (other project), P3R02S1 (other project), P3R02BS (other project), EC305401 (other project) FS+10d, P3C02D4 (other project) FS+10d, XC205401 FS-20d, ER445401 (other project), XC310C00 |  |  |  | 17d | 0d | start on or after 2011-09-12 | TB26 - V - Construct-Winter partly * |  |  |  |  |  |  |  |  |  |  |  |  |  | XC305401 |  | 0 | 0 |  |  | 934 | 54 | 200 | 200 | C | CiC |  | X | C | XC30 | 5401 | C | 54 | X | mis | LND | 5401 |  |  |  | 1 | 27.8. |  |  |  |  |
| XC195401 |  | CA54 SR5401 - Backfill |  | 30d | 2011-10-05 | 2011-11-10 | XC305401 SS+20d, XC305401 FF+10d, XC915401 FF+10d |  |  |  | 87d | 0d |  | TB26 - T - Construct-Winter-3 (Dec/Jan/Feb free) * | Backfill & Compaction [3100 cbm]; Backfill & Compaction [4650 h] | 279,000 |  | 4650,00 |  |  |  |  |  |  |  |  |  | XC195401 |  | 4650 | 0 |  |  | 934 | 54 | 200 | 200 | C | CiC |  | X | C | XC19 | 5401 | C | 54 | X | mis | LND | 5401 | MO11 |  |  |  |  |  |  |  |  |
| XC605401 |  | CA54 SR5401 - Paving |  | 20d | 2011-11-14 | 2012-03-14 | XN205401, XC195401 |  |  |  | 87d | 149.5d |  | TB26 - T - Construct-Winter-3 (Dec/Jan/Feb free) * | Gravel [600 sqm]; Gravel [30 h] | 1,844.02 |  | 30,00 |  |  |  |  |  |  |  |  |  | XC605401 |  | 30 | 0 |  |  | 934 | 54 | 200 | 200 | C | CiC |  | X | C | XC60 | 5401 | C | 54 | X | PV | LND | 5401 | MO11 |  |  | 1 |  |  |  |  |  |
|  | N | **Structural Steel** |  |  | 2011-02-21 | 2011-10-11 |  |  |  |  |  |  |  |  |  |  |  |  |  |  |  |  |  |  |  |  |  |  |  |  |  |  |  |  |  |  |  |  |  |  |  |  |  |  |  |  |  |  |  |  |  |  |  |  |  |  |  |  |  |
| XN705401 |  | CA54 SR5401 - KMD Assy Drawings | milestone | 0d | 2011-02-21 A | 2011-02-21 A |  | 100% |  |  |  |  | finish on 2011-02-21 |  |  |  |  | 22t |  |  |  |  |  |  |  |  |  | XN705401 | x | 0 | 0 |  |  | 934 | 54 | 200 | 200 | C | LND | KMD | X | N | XN05 | 5401 | N | 54 | X | PR | LND | 5401 |  | XNK |  |  |  | to be confirmed |  |  |  |
| XN715401 |  | CA54 SR5401 - Steel Deliveries | milestone | 0d | 2011-02-28 A | 2011-02-28 A |  | 100% |  |  |  |  | finish on 2011-04-01 | TB26 - V - Construct-Winter partly * |  |  |  | 130 |  |  | E-04-26 |  |  |  |  |  |  | XN715401 |  | 0 | 0 |  |  | 934 | 54 | 200 | 200 | C | LND | SD | X | N | XN06 | 5401 | N | 54 | X | PR | LND | 5401 |  | XNK |  |  |  |  |  |  |  |
| XN205401 |  | CA54 SR5401 - Installation Steel Structure |  | 64d | 2011-03-14 A | 2011-05-31 A | XN705401, XN715401 FS+5d, P3N01GN (other project), XC915401, EN685401 (other project), P3N012D (other project) FS+10d | 100% |  |  |  |  |  | TB26 - V - Construct-Winter partly * | Piperacks, Main Structures [122 t]; Piperacks, Main structures [5185 h] | 207,400 | 207,400 | 5185,00 |  |  | E-04-30 | t |  |  |  |  |  | XN205401 |  | 5185 | 5185 |  |  | 934 | 54 | 200 | 200 | C | LND |  | X | N | XN20 | 5401 | N | 54 | X | PR | LND | 5401 | ChSK | XNK |  |  | x |  | x |  |  |
| XN405401 |  | CA54 SR5401 - Install Railings,Ladders,etc. |  | 20d | 2011-09-19 | 2011-10-11 | XN205401, XE405401 |  |  |  | 214d | 0d | start on or after 2011-09-19 |  | Ladders & platforms [2 t]; Ladders & platforms [200 h] | 362.15 |  | 200,00 |  |  |  |  |  |  |  |  |  | XN405401 | x | 200 | 0 |  |  | 934 | 54 | 200 | 200 | C | LND |  | X | N | XN40 | 5401 | N | 51 | X | SS | LND | 5401 | ChSK | XNK |  |  | 27.8. |  |  | UDF_G4 | Check Roof - Cladding |

Notes:
- XW505301: P3 Activity Log Info: Clarification Surface Protection during Prefab
- XC115401: P3 Activity Log Info: incl. Dewatering/Drainage
- XC155401: P3 Activity Log Info: 106 driven piles expected,20/d/machine
- XC205401: Current Status: 12.01.2011 (Oxana): das Enddatum auf den 11-Jan-2011 verschoben, da laut PMR / nicht abgeschlossen.
- XC305401: P3 Activity Log Info: Clarification Prefab Catch Basins/pulling / pits / Current Status: 12.0.2011 (O. Siegel): nach Rьcksprache mit MO11 am 11 und / 12.Januar 11, wurde der 25-April-11 als Starttermin besprochen.
- XN715401: Scope: 09.02.2011: weight: 120 ton
- XN205401: Current Status: 13.05.2011 nach Rьcksprache mit Civil: nicht vor Ende Mai / kann die Brьcke an URMA ьbergeben werden.

| ID | WBS | Activity | Duration | Start | Finish | Predecessors | Complete | Remaining | Planned start | Planned finish | Total float | Free float | Constraint | Calendar | Resources | Cost | Actual cost | TB26 Ressource Budget | UDF_SELECT UPDATE PROGRESS | UDF_SAVE ACT ID | UDF_BUDGETED LABOR UNIT | UDF_ACTUAL LABOR UNIT | UDF_COMMENTS_0827 | Department | Constr. Area | PMT-Area | PMT-Schedule Org | PMT-Phase | PMT-Respons. | WBS Phase | WBS Discipline | WBS Type of Work | WBS Objects | Russia WBS Discipline (Russia) | Russia Construction Area | Russia WBS Phase | IMS | UPT | Russia WBS Objects | 4 week lookahead | UDF_CONTRACT ITEM | UDF_CONTRACT START DATE | UDF_PLANNED START | UDF_CONTRACT FINISH DATE | UDF_PLANNED FINISH | Subcontractor | UDF_CONTRACT FINISH DATE REV1 | UDF_CONTRACT START DATE REV1 | UDF_INDICATOR | UDF_CONTRACT INDICATOR | TB26 Semantics | TB26 Material Res Values | UDF_ELECTRICAL START | UDF_ELECTRICAL FINISH | UDF_CHECK BASELINE | UDF_CHECK RESOURCE DATES | UDF_Vendor Representatives | UDF_CONTRACT FINISH DATE REV2 | UDF_CONTRACT START DATE REV2 |
| --- | --- | --- | --- | --- | --- | --- | --- | --- | --- | --- | --- | --- | --- | --- | --- | --- | --- | --- | --- | --- | --- | --- | --- | --- | --- | --- | --- | --- | --- | --- | --- | --- | --- | --- | --- | --- | --- | --- | --- | --- | --- | --- | --- | --- | --- | --- | --- | --- | --- | --- | --- | --- | --- | --- | --- | --- | --- | --- | --- |
|  | H | **HVAC** |  |  |  |  |  |  |  |  |  |  |  |  |  |  |  |  |  |  |  |  |  |  |  |  |  |  |  |  |  |  |  |  |  |  |  |  |  |  |  |  |  |  |  |  |  |  |  |  |  |  |  |  |  |  |  |  |  |
|  | U | **Package Units** |  |  |  |  |  |  |  |  |  |  |  |  |  |  |  |  |  |  |  |  |  |  |  |  |  |  |  |  |  |  |  |  |  |  |  |  |  |  |  |  |  |  |  |  |  |  |  |  |  |  |  |  |  |  |  |  |  |
|  | B | **Mechanical - Stationary Equipment** |  |  |  |  |  |  |  |  |  |  |  |  |  |  |  |  |  |  |  |  |  |  |  |  |  |  |  |  |  |  |  |  |  |  |  |  |  |  |  |  |  |  |  |  |  |  |  |  |  |  |  |  |  |  |  |  |  |
|  | M | **Mechanical - Rotating Equipment** |  |  |  |  |  |  |  |  |  |  |  |  |  |  |  |  |  |  |  |  |  |  |  |  |  |  |  |  |  |  |  |  |  |  |  |  |  |  |  |  |  |  |  |  |  |  |  |  |  |  |  |  |  |  |  |  |  |
|  | R | **Piping** |  | 2011-10-01 | 2011-11-22 |  |  |  |  |  |  |  |  |  |  |  |  |  |  |  |  |  |  |  |  |  |  |  |  |  |  |  |  |  |  |  |  |  |  |  |  |  |  |  |  |  |  |  |  |  |  |  |  |  |  |  |  |  |  |
| XR205401 |  | CA54 SR5401 - Piping Prefabrication | 10d | 2011-10-01 | 2011-10-12 | ER495401 (other project) FS-5d |  |  |  |  | -14d | 0d | start on or after 2011-10-01 |  | A/G piping prefabrication [25 Fpi]; A/G Piping (Prefab) [93.75 h] | 121.95 |  | 93,75 | 27.8. | XR205401 | 93,75 | 0 | Start 01.10.11 | 934 | 54 | 200 | 200 | C | LND | X | R | XR20 | 5401 | R | 54 | X | PRP | LND | 5401 | x |  |  |  |  |  |  |  |  |  |  |  |  |  |  |  |  |  |  |  |
| XR605401 |  | CA54 SR5401 - Piping Pressure Tests | 20d | 2011-10-18 | 2011-11-14 | XR405401 FS-11d, X0300020 |  |  |  |  | -14d | 0d |  | TB26 - T - Construct-Winter-3 (Dec/Jan/Feb free) * |  |  |  | 8 |  | XR605401 | 0 | 0 |  | 934 | 54 | 200 | 200 | C | LND | X | R | XR60 | 5401 | R | 54 | X | HY | LND | 5401 |  | E-06-03-12 |  |  |  |  |  |  |  |  |  |  |  |  |  |  |  |  |  |  |
| XR405401 |  | CA54 SR5401 - Piping Installation | 10d | 2011-10-19 | 2011-10-29 | XN205401, XE405401, XR205401 SS+10d, IMS-C-000190 FF, ER475401 (other project) FS-20d, XW505401 |  |  |  |  | -14d | 0d | start on or after 2011-09-01 | TB26 - V - Construct-Winter partly * | A/G piping field installation [50 Fpi]; A/G Piping (Field) [312.5 h] | 428.67 |  | 312,50 |  | XR405401 | 312,5 | 0 |  | 934 | 54 | 200 | 200 | C | LND | X | R | XR40 | 5401 | R | 54 | X | PI | LND | 5401 |  | E-06-03-12 | 2011-01-20 | 2011-03-17 |  |  |  |  |  |  |  |  |  |  |  |  |  |  |  |  |
| XR805401 |  | CA54 SR5401 - Piping Reinstatement | 10d | 2011-11-07 | 2011-11-22 | XR605401 FF+5d, IMS-C-000360 FF |  |  |  |  | 369.5d |  |  | TB26 - V - Construct-Winter partly * |  |  |  | 4 |  | XR805401 | 0 | 0 |  | 934 | 54 | 200 | 200 | C | LND | X | R | XR80 | 5401 | R | 54 | X | PI | LND | 5401 |  | E-06-03-12 |  |  | 2011-07-30 | 2011-09-22 |  |  |  |  |  |  |  |  |  |  |  |  |  |  |
|  | E | **Electrical** |  | 2010-09-21 | 2012-09-12 |  |  |  |  |  |  |  |  |  |  |  |  |  |  |  |  |  |  |  |  |  |  |  |  |  |  |  |  |  |  |  |  |  |  |  |  |  |  |  |  |  |  |  |  |  |  |  |  |  |  |  |  |  |  |
| XC915401 |  | CA54 SR5401 - Installation Earthing Foundations_CIVIL | 68d | 2010-09-21 A | 2011-01-12 A | EE905401 (other project), XC205401 FF+10d | 100% |  |  |  |  |  |  | TB26 - V - Construct-Winter partly * | Grounding & Lightning [130 pcs]; Grounding & Lightning [1462.5 h] | 58,500 | 58,500 | 1462,50 |  | XC915401 | 1462,5 | 1462,5 |  | 934 | 54 | 200 | 200 | C | LND | X | C | XE91 | 5401 | C | 54 | X | EA | LND | 5401 |  | E-16-07-17 | 2011-03-20 |  | 2011-08-30 |  | MO11 |  |  |  |  |  |  |  |  |  |  |  |  |  |
| XE915401 |  | CA54 SR5401 - Installation Earthing Foundations_E/I | 15d | 2011-05-27 A | 2011-06-14 A | XN205401 | 100% |  |  |  |  |  |  | TB26 - V - Construct-Winter partly * |  |  |  | 150 |  | XE915401 | 0 | 0 |  | 934 | 54 | 200 | 200 | C | LND | X | E | XE91 | 5401 | E | 54 | X | EA | LND | 5401 |  | E-16-07-17 | 2011-03-20 |  | 2011-08-30 |  | URMA | 2012-04-10 | 2011-05-23 | UDF_G2 |  |  |  |  |  |  |  |  |  |  |
| XE405401 |  | CA54 SR5401 - Install Cable Trays | 65d | 2011-05-31 A | 2011-07-19 A | XN205401, P3E16S (other project), EE46540110 (other project), XN205102l FF+20d | 100% |  | 2011-05-31 | 2011-08-15 |  |  |  | TB26 - V - Construct-Winter partly * | Cable trays/conduits [3740 m]; Cable trays [11220 h] | 448,800 | 314,160 | 11220,00 |  | XE405401 | 11220 | 7854 |  | 934 | 54 | 200 | 200 | C | LND | X | E | XE40 | 5401 | E | 54 | X | EL | LND | 5401 |  | E-15-01-04 | 2011-03-20 |  | 2011-05-20 |  | URMA | 2011-09-15 | 2011-05-23 | UDF_G2 | UDF_G4 | m | 2900 | 2011-04-16 | 2011-06-28 | x |  |  |  |  |
| XE705401 |  | CA54 SR5401 - Install Lighting & Small Power | 23d | 2011-08-11 A | 2011-09-09 | P3E09S (other project), XP341610 FS+40d, XE405401, EE76510110 (other project), EE765401 (other project), P3E03S2 (other project) |  | 12d | 2011-08-11 | 2011-09-06 | 194d | 80d |  | TB26 - V - Construct-Winter partly * | Cable Pulling [1200 m]; Lighting illuminates [110 pcs]; Lighting (iluminates) [1100 h]; Cable pulling [600 h] | 68,000 | 38,080 | 1700,00 | 27.8. | XE705401 | 1700 | 0 |  | 934 | 54 | 200 | 200 | C | LND | X | E | XE70 | 5401 | E | 54 | X | EL | LND | 5401 |  | E-16-03-01 | 2011-05-10 |  | 2012-01-31 |  | URMA | 2012-05-10 | 2011-08-15 | UDF_G2 |  |  |  |  |  |  | x |  |  |  |
| XE805401 |  | CA54 SR5401 - Install Heat Tracing | 50d | 2011-10-29 | 2012-02-15 | P3E19S (other project), XW505401 FF+5d, E3E1950 (other project), XE705401 FF+12d, XR605401 FS-10d |  |  |  |  | 119d | 36d |  | TB26 - V - Construct-Winter partly * | Electrical Heat Tracing [2600 m]; Electrical heat tracing [1300 h] | 52,000 |  | 1300,00 |  | XE805401 | 1300 | 0 |  | 934 | 54 | 200 | 200 | C | LND | X | E | XE80 | 5401 | E | 54 | X | HT | LND | 5401 |  | E-16-04-01 | 2011-06-20 |  | 2012-03-20 |  | URMA | 2012-06-30 | 2011-09-15 | UDF_G2 |  |  |  |  |  |  |  | 005 | 2012-04-10 | 2011-05-23 |
| XE505401 |  | CA54 SR5401 - Cable Pulling Electric | 100d | 2012-05-17 | 2012-09-12 | XE505402 SS, XE500C01, P3E15AS (other project), XE411610, EE565401 (other project), XE405401 SS+40d, P3E15BS (other project) FF+20d, P3E15CS (other project) FF+20d |  |  |  |  | -97.5d | 0d |  | TB26 - V - Construct-Winter partly * | Cable Pulling [17900 m]; Cable pulling [8950 h] | 358,000 |  | 8950,00 |  | XE505401 | 8950 | 0 |  | 934 | 54 | 200 | 200 | C | LND | X | E | XE50 | 5401 | E | 54 | X | EL | LND | 5401 |  | E-16-01-01 | 2011-05-20 |  | 2012-02-10 |  | URMA | 2012-07-01 | 2011-10-01 | UDF_G1 |  | m | 18500 | 2011-07-19 | 2011-11-16 |  |  |  |  |  |
|  | J | **Instrumentation** |  | 2011-07-04 | 2012-07-16 |  |  |  |  |  |  |  |  |  |  |  |  |  |  |  |  |  |  |  |  |  |  |  |  |  |  |  |  |  |  |  |  |  |  |  |  |  |  |  |  |  |  |  |  |  |  |  |  |  |  |  |  |  |  |
| XJ425401 |  | CA54 SR5401 - Install CableTrays Instrumentation | 47d | 2011-07-04 A | 2011-08-26 A | XE405401, EJ46540110 (other project) | 100% |  |  |  |  |  | as late as possible | TB26 - V - Construct-Winter partly * | Main cable trays [700 m]; Install Main Cable trays [2100 h] | 84,000 |  | 2100,00 |  | XJ425401 | 2100 | 0 |  | 934 | 54 | 200 | 200 | C | LND | X | J | XJ42 | 5401 | J | 54 | X | IN | LND | 5401 |  | E-15-01-04 | 2011-03-20 |  | 2011-05-20 |  | URMA | 2011-09-15 | 2011-05-23 | UDF_G2 |  | m | 1655 | 2011-04-16 | 2011-06-28 | x |  |  |  |  |
| XJ525401 |  | CA54 SR5401 - Pulling Instrument Cables | 50d | 2012-05-17 | 2012-07-16 | XJ525402 SS, XE500C01, P3J17S (other project), XJ425401, P3J17S1 (other project), XE505401 SS |  |  |  |  | -97.5d | 0d |  | TB26 - V - Construct-Winter partly * | Multicore cables [6200 m]; Pull multicore cables [3100 h] | 124,000 |  | 3100,00 |  | XJ525401 | 3100 | 0 | to be checked | 934 | 54 | 200 | 200 | C | LND | X | J | XJ52 | 5401 | J | 54 | X | IN | LND | 5401 |  | E-17-04-17 | 2011-03-20 |  | 2011-09-20 |  | URMA | 2012-03-30 | 2011-08-10 | UDF_G2 |  | m | 4500 | 2011-07-16 | 2011-09-12 |  |  |  |  |  |
|  | S | **Safety & Environment** |  |  |  |  |  |  |  |  |  |  |  |  |  |  |  |  |  |  |  |  |  |  |  |  |  |  |  |  |  |  |  |  |  |  |  |  |  |  |  |  |  |  |  |  |  |  |  |  |  |  |  |  |  |  |  |  |  |
|  | W | **Painting** |  | 2011-10-07 | 2011-10-18 |  |  |  |  |  |  |  |  |  |  |  |  |  |  |  |  |  |  |  |  |  |  |  |  |  |  |  |  |  |  |  |  |  |  |  |  |  |  |  |  |  |  |  |  |  |  |  |  |  |  |  |  |  |  |
| XW505401 |  | CA54 SR5401 - Surf.Protection Piping | 10d | 2011-10-07 | 2011-10-18 | XR205401 FF+5d |  |  |  |  | -14d | 0d | as late as possible |  | Piping painting [10 sqm]; Piping painting [25 h] | 424.24 |  | 25,00 | 27.8. | XW505401 | 25 | 0 |  | 934 | 54 | 200 | 200 | C | LND | X | W | XW50 | 5401 | W | 54 | X | PA | LND | 5401 |  |  |  |  |  |  |  |  |  |  |  |  |  |  |  |  |  |  |  |  |
|  | V | **Insulation** |  | 2012-03-01 | 2012-05-18 |  |  |  |  |  |  |  |  |  |  |  |  |  |  |  |  |  |  |  |  |  |  |  |  |  |  |  |  |  |  |  |  |  |  |  |  |  |  |  |  |  |  |  |  |  |  |  |  |  |  |  |  |  |  |
| XV505401 |  | CA54 SR5401 - Insulation Piping | 60d | 2012-03-01 | 2012-05-18 | XE805401 FF+20d, XE805401 SS+20d |  |  |  |  | 83d | 98.5d |  | TB26 - T - Construct-Winter-3 (Dec/Jan/Feb free) * | Piping insulation [20 sqm]; Piping insulation [150 h] | 1,614.17 |  | 150,00 |  | XV505401 | 150 | 0 |  | 934 | 54 | 200 | 200 | C | LND | X | V | XV50 | 5401 | V | 54 | X | INS | LND | 5401 |  | E-13-01 |  |  | 2012-04-30 |  |  |  |  |  |  |  |  |  |  |  |  |  |  |  |

Notes:
- XR205401: Current Status: 10.03.2011 (O.Siegel): ENG ist noch nicht abgeschlossen. / Auf dem Piperack sind nur die HVAC-Rohre. Nach Absprache mit M. Siegel wurde / Startdatum fьr Piping Prefabrication auf Ende April 2011 gesetzt.
- XR405401: Current Status: 10.03.2011 (O.Siegel): ENG ist noch nicht abgeschlossen. / Auf dem Piperack sind nur die HVAC-Rohre. Nach Absprache mit M. Siegel wurde / Startdatum fьr Piping Prefabrication auf Ende April 2011 gesetzt.
- XE915401: UDF_PREDECESSOR: XN30, DEL XE40, DEL XE80, DEL XJ40, Civil 100%, Equipment 100%
- XE405401: UDF_PREDECESSOR: XN30, Piping 50%
- XE705401: UDF_PREDECESSOR: XE40, Civil 100%, HVAC ducts, Finishing works partly
- XE805401: UDF_PREDECESSOR: XR40, Piping 50% pressure tests
- XE505401: UDF_PREDECESSOR: XE40, XE50, DEL XE34
- XJ425401: UDF_PREDECESSOR: XE40, XJ32, Equipment 100%, Piping 50%
- XJ525401: UDF_PREDECESSOR: XE40, XJ32, XJ52
- XW505401: P3 Activity Log Info: Clarification Surface Protection during Prefab

| ID | WBS | Activity | Type | Duration | Start | Finish | Predecessors | Complete | Remaining | Planned start | Planned finish | Total float | Free float | Constraint | Calendar | Resources | Cost | Actual cost | UDF_SAVE ACT ID | UDF_BUDGETED LABOR UNIT | UDF_ACTUAL LABOR UNIT | Department | Constr. Area | PMT-Area | PMT-Schedule Org | PMT-Phase | PMT-Respons. | WBS Phase | WBS Discipline | WBS Type of Work | WBS Objects | Russia WBS Discipline (Russia) | Russia Construction Area | Russia WBS Phase | IMS | UPT | Russia WBS Objects | Subcontractor | TB26 Ressource Budget | Inquiry/Order No | UDF_Concrete | UDF_SELECT UPDATE PROGRESS | Comments | UDF_CHECK BASELINE | Type of Work | Zeigen/n. Zeigen | UDF_CONTRACT ITEM | TB26 Semantics | 4 week lookahead | UDF_CONTRACT INDICATOR | UDF_CHECK CRITICAL PATH | UDF_COMMENTS_0827 | UDF_CONTRACT START DATE | UDF_PLANNED START | UDF_CONTRACT FINISH DATE | UDF_PLANNED FINISH | TB26 Material Res Values | UDF_ELECTRICAL START | UDF_ELECTRICAL FINISH | UDF_CONTRACT FINISH DATE REV1 | UDF_CONTRACT START DATE REV1 | UDF_CHECK RESOURCE DATES | UDF_INDICATOR | UDF_Vendor Representatives |
| --- | --- | --- | --- | --- | --- | --- | --- | --- | --- | --- | --- | --- | --- | --- | --- | --- | --- | --- | --- | --- | --- | --- | --- | --- | --- | --- | --- | --- | --- | --- | --- | --- | --- | --- | --- | --- | --- | --- | --- | --- | --- | --- | --- | --- | --- | --- | --- | --- | --- | --- | --- | --- | --- | --- | --- | --- | --- | --- | --- | --- | --- | --- | --- | --- |
|  | 02 | **CA5402** |  |  | 2008-09-24 | 2012-09-12 |  |  |  |  |  |  |  |  |  |  |  |  |  |  |  |  |  |  |  |  |  |  |  |  |  |  |  |  |  |  |  |  |  |  |  |  |  |  |  |  |  |  |  |  |  |  |  |  |  |  |  |  |  |  |  |  |  |  |
|  | C | **Civil Work** |  |  | 2008-09-24 | 2012-03-29 |  |  |  |  |  |  |  |  |  |  |  |  |  |  |  |  |  |  |  |  |  |  |  |  |  |  |  |  |  |  |  |  |  |  |  |  |  |  |  |  |  |  |  |  |  |  |  |  |  |  |  |  |  |  |  |  |  |  |
| XC115402 |  | CA54 SR5402 - Excavation&Surface Prep by U/I/O |  | 294d | 2008-09-24 A | 2009-09-30 A | XC115401 SS | 100% |  |  |  |  |  |  |  |  |  |  | XC115402 | 0 | 0 | 934 | 54 | 200 | 200 | C | UIO | X | C | XC11 | 5402 | C | 54 | X | CW | LND | 5402 | MO11 |  |  |  |  |  |  |  |  |  |  |  |  |  |  |  |  |  |  |  |  |  |  |  |  |  |  |
| XC11540205 |  | CA54 SR5402 - Excavation |  | 9d | 2010-04-26 A | 2010-05-06 A | XC11160005 SS, XC11160005 FF+3d | 100% |  |  |  |  |  |  |  | Excavation [1650 cbm]; Excavation [825 h] | 66,000 | 66,000 | XC11540205 | 825 | 825 | 934 | 54 | 200 | 200 | C | MO02 | X | C | XC11 | 5402 | C | 10 | X | P | LND | 1010 | MO11 | 825,00 | 999 |  |  |  |  |  |  |  |  |  |  |  |  |  |  |  |  |  |  |  |  |  |  |  |  |
| XC11540210 |  | CA54 SR5402 - SubBase (Gravel/Geogrid) for Concrete |  | 12d | 2010-05-14 A | 2010-05-28 A | XC11540205 FS+6d | 100% |  | 2010-05-14 | 2010-05-27 |  |  |  |  | Sub Base for Concrete/Paving&Roads (Gravel) [250 cbm]; Subbase for Concrete [250 h] | 25,000 | 8,000 | XC11540210 | 250 | 250 | 934 | 54 | 200 | 200 | C | MO02 | X | C | XC11 | 5402 | C | 10 | X | P | LND | 1010 | MO11 | 250,00 | 999 |  |  |  |  |  |  |  |  |  |  |  |  |  |  |  |  |  |  |  |  |  |  |  |  |
| XC155402 |  | CA54 SR5402 - Piling |  | 4d | 2010-09-16 A | 2010-09-20 A | XC155401, XC11540205 FS+10d, EC155402 (other project) FS+4d, XC115402, XC11540210, F2910, XC151700 | 100% |  |  |  |  |  |  |  | Piles driven [32 pcs]; Piles driven [240 h] | 9,600 | 9,600 | XC155402 | 240 | 240 | 934 | 54 | 200 | 200 | C | MO02 | X | C | XC15 | 5402 | C | 54 | X | P | LND | 5402 | MO11 | 240,00 |  |  |  |  |  |  |  |  |  |  |  |  |  |  |  |  |  |  |  |  |  |  |  |  |  |
| XC205402 |  | CA54 SR5402 - Concrete Works |  | 28d | 2010-10-30 A | 2010-12-22 A | XC155402, XC205401 FF+3d, EC45540205 (other project), EC285402 (other project) FS+10d | 100% |  |  |  |  |  |  | TB26 - V - Construct-Winter partly * | Concrete works [80 cbm]; Concrete works [2400 h] | 96,000 | 96,000 | XC205402 | 2400 | 2400 | 934 | 54 | 200 | 200 | C | MO04 | X | C | XC20 | 5402 | C | 54 | X | mis | LND | 5402 | MO11 | 2400,00 |  |  |  |  |  |  |  |  |  |  |  |  |  |  |  |  |  |  |  |  |  |  |  |  |  |
| XC305402 |  | CA54 SR5402 - UG Installation (incl. Precast Manholes) |  | 78d | 2011-09-05 | 2011-12-27 | XC205402 FS-20d, P3R02S1 (other project), P3R02BS (other project), EC305402 (other project) FS+10d, ER445402 (other project), P3C02D4 (other project) FS+10d, XC310C00, XC300C00, P3R02AS1 (other project) |  |  |  |  | 23d | 15d |  | TB26 - V - Construct-Winter partly * |  |  |  | XC305402 | 0 | 0 | 934 | 54 | 200 | 200 | C | CiC | X | C | XC30 | 5402 | C | 54 | X | mis | LND | 5402 |  |  |  | 1 | 27.8. |  |  |  |  |  |  |  |  |  |  |  |  |  |  |  |  |  |  |  |  |  |  |
| XC195402 |  | CA54 SR5402 - Backfill |  | 30d | 2011-10-18 | 2012-03-01 | XC305402 FF+10d, XC305402 SS+20d, XC915402 FF+10d |  |  |  |  | 123d | 0d |  | TB26 - T - Construct-Winter-3 (Dec/Jan/Feb free) * | Backfill & Compaction [2300 cbm]; Backfill & Compaction [3450 h] | 207,000 |  | XC195402 | 3450 | 0 | 934 | 54 | 200 | 200 | C | CiC | X | C | XC19 | 5402 | C | 54 | X | mis | LND | 5402 | MO11 | 3450,00 |  |  |  |  |  |  |  |  |  |  |  |  |  |  |  |  |  |  |  |  |  |  |  |  |  |
| XC605402 |  | CA54 SR5402 - Paving |  | 20d | 2012-03-01 | 2012-03-29 | XC195402, XN205402 |  |  |  |  | 123d | 138.5d |  | TB26 - T - Construct-Winter-3 (Dec/Jan/Feb free) * | Gravel [300 sqm]; Gravel [15 h] | 3,015.48 |  | XC605402 | 15 | 0 | 934 | 54 | 200 | 200 | C | CiC | X | C | XC60 | 5402 | C | 54 | X | PV | LND | 5402 | MO11 | 15,00 |  | 1 |  |  |  |  |  |  |  |  |  |  |  |  |  |  |  |  |  |  |  |  |  |  |  |
|  | N | **Structural Steel** |  |  | 2011-02-21 | 2011-10-11 |  |  |  |  |  |  |  |  |  |  |  |  |  |  |  |  |  |  |  |  |  |  |  |  |  |  |  |  |  |  |  |  |  |  |  |  |  |  |  |  |  |  |  |  |  |  |  |  |  |  |  |  |  |  |  |  |  |  |
| XN705402 |  | CA54 SR5402 - KMD Assy Drawings | milestone | 0d | 2011-02-21 A | 2011-02-21 A |  | 100% |  |  |  |  |  | finish on 2011-02-21 |  |  |  |  | XN705402 | 0 | 0 | 934 | 54 | 200 | 200 | C | LND | X | N | XN05 | 5402 | N | 54 | X | PR | LND | 5402 |  | 22t |  |  |  | to be confirmed | x | XNK | KMD |  |  |  |  |  |  |  |  |  |  |  |  |  |  |  |  |  |  |
| XN715402 |  | CA54 SR5402 - Steel Deliveries | milestone | 0d | 2011-02-28 A | 2011-02-28 A |  | 100% |  |  |  |  |  | finish on 2011-04-18 | TB26 - V - Construct-Winter partly * |  |  |  | XN715402 | 0 | 0 | 934 | 54 | 200 | 200 | C | LND | X | N | XN06 | 5402 | N | 54 | X | PR | LND | 5402 |  | 130 |  |  |  |  |  | XNK | SD | E-04-26 |  |  |  |  |  |  |  |  |  |  |  |  |  |  |  |  |  |
| XN205402 |  | CA54 SR5402 - Installation Steel Structure |  | 21d | 2011-05-12 A | 2011-06-04 A | XC205402, XC915402, P3N012D (other project) FS+10d, P3N01HN (other project), EN685402 (other project), XN205401 SS, XN715402 FS+10d, XN705402 | 100% |  |  |  |  |  | start on or after 2011-04-25 | TB26 - V - Construct-Winter partly * | Piperacks, Main Structures [35 t]; Piperacks, Main structures [1487.5 h] | 59,500 | 59,500 | XN205402 | 1487,5 | 1487,5 | 934 | 54 | 200 | 200 | C | LND | X | N | XN20 | 5402 | N | 54 | X | PR | LND | 5402 | ChSK | 1487,50 |  |  |  |  |  | XNK |  | E-04-31 | t | x |  |  |  |  |  |  |  |  |  |  |  |  |  |  |  |
| XN405402 |  | CA54 SR5402 - Install Railings,Ladders,etc. |  | 20d | 2011-09-19 | 2011-10-11 | XN205402, XE405402, XN405401 SS |  |  |  |  | 214d | 0d |  |  | Ladders & platforms [1 t]; Ladders & platforms [100 h] | 362.15 |  | XN405402 | 100 | 0 | 934 | 54 | 200 | 200 | C | LND | X | N | XN40 | 5402 | N | 51 | X | SS | LND | 5402 | ChSK | 100,00 |  |  |  |  | x | XNK |  |  |  |  | UDF_G4 | Check Roof - Cladding |  |  |  |  |  |  |  |  |  |  |  |  |  |
| XN605402 |  | CA54 SR5402 - Install Gratings |  | 10d | 2011-09-19 | 2011-09-29 | XN405402 SS |  |  |  |  | 224d | 286.5d |  |  | Grating [15 sqm]; Grating [56.25 h] | 1,241.67 |  | XN605402 | 56,25 | 0 | 934 | 54 | 200 | 200 | C | LND | X | N | XN60 | 5402 | N | 51 | X | SS | LND | 5402 | ChSK | 56,25 |  |  |  |  | x | XNK |  |  |  |  | UDF_G4 | Check Roof - Cladding |  |  |  |  |  |  |  |  |  |  |  |  |  |
|  | R | **Piping** |  |  | 2011-10-01 | 2011-11-24 |  |  |  |  |  |  |  |  |  |  |  |  |  |  |  |  |  |  |  |  |  |  |  |  |  |  |  |  |  |  |  |  |  |  |  |  |  |  |  |  |  |  |  |  |  |  |  |  |  |  |  |  |  |  |  |  |  |  |
| XR205402 |  | CA54 SR5402 - Piping Prefabrication |  | 10d | 2011-10-01 | 2011-10-12 | ER495402 (other project) FS+10d |  |  |  |  | -25d | 0d | start on or after 2011-10-01 |  | A/G piping prefabrication [25 Fpi]; A/G Piping (Prefab) [93.75 h] | 121.95 |  | XR205402 | 93,75 | 0 | 934 | 54 | 200 | 200 | C | LND | X | R | XR20 | 5402 | R | 54 | X | PRP | LND | 5402 |  | 93,75 |  |  | 27.8. | to be dissolved |  |  |  |  |  | x |  |  | Start 01.10.11 |  |  |  |  |  |  |  |  |  |  |  |  |
| XR405402 |  | CA54 SR5402 - Piping Installation |  | 10d | 2011-10-19 | 2011-10-29 | IMS-C-000190 FF, ER475402 (other project) FS-20d, XR205402 SS+10d, XN205402, XW505402 |  |  |  |  | -25d | 0d | start on or after 2011-09-01 | TB26 - V - Construct-Winter partly * | A/G piping field installation [50 Fpi]; A/G Piping (Field) [312.5 h] | 428.67 |  | XR405402 | 312,5 | 0 | 934 | 54 | 200 | 200 | C | LND | X | R | XR40 | 5402 | R | 54 | X | PI | LND | 5402 |  | 312,50 |  |  |  | to be dissolved |  |  |  | E-06-03-12 |  |  |  |  |  | 2011-01-20 | 2011-03-02 |  |  |  |  |  |  |  |  |  |  |
| XR605402 |  | CA54 SR5402 - Piping Pressure Tests |  | 20d | 2011-10-20 | 2011-11-16 | XR605401 SS, X0300020, XR405402 FS-9d |  |  |  |  | -16d | 0d |  | TB26 - T - Construct-Winter-3 (Dec/Jan/Feb free) * |  |  |  | XR605402 | 0 | 0 | 934 | 54 | 200 | 200 | C | LND | X | R | XR60 | 5402 | R | 54 | X | HY | LND | 5402 |  | 8 |  |  |  |  |  |  |  | E-06-03-12 |  |  |  |  |  |  |  |  |  |  |  |  |  |  |  |  |  |
| XR805402 |  | CA54 SR5402 - Piping Reinstatement |  | 10d | 2011-11-09 | 2011-11-24 | IMS-C-000360 FF, XR605402 FF+5d |  |  |  |  | 367.5d |  |  | TB26 - V - Construct-Winter partly * |  |  |  | XR805402 | 0 | 0 | 934 | 54 | 200 | 200 | C | LND | X | R | XR80 | 5402 | R | 54 | X | PI | LND | 5402 |  | 4 |  |  |  |  |  |  |  | E-06-03-12 |  |  |  |  |  |  |  | 2011-07-30 | 2011-09-08 |  |  |  |  |  |  |  |  |
|  | E | **Electrical** |  |  | 2010-10-30 | 2012-09-12 |  |  |  |  |  |  |  |  |  |  |  |  |  |  |  |  |  |  |  |  |  |  |  |  |  |  |  |  |  |  |  |  |  |  |  |  |  |  |  |  |  |  |  |  |  |  |  |  |  |  |  |  |  |  |  |  |  |  |
| XC915402 |  | CA54 SR5402 - Installation Earthing Foundations_CIVIL |  | 33d | 2010-10-30 A | 2011-01-11 A | EE905402 (other project), XC205402 FF+5d | 100% |  |  |  |  |  |  | TB26 - V - Construct-Winter partly * | Grounding & Lightning [170 pcs]; Grounding & Lightning [1912.5 h] | 76,500 | 76,500 | XC915402 | 1912,5 | 1912,5 | 934 | 54 | 200 | 200 | C | LND | X | C | XE91 | 5402 | C | 54 | X | EA | LND | 5402 | MO11 | 1912,50 |  |  |  |  |  |  |  | E-16-07-17 |  |  |  |  |  | 2011-03-20 |  | 2011-08-30 |  |  |  |  |  |  |  |  |  |
| XE405402 |  | CA54 SR5402 - Install Cable Trays |  | 107d | 2011-05-14 A | 2011-09-16 | XN205402, EE46540210 (other project), P3E16S (other project) | 100% | 18d |  |  | -15d | 1d |  | TB26 - V - Construct-Winter partly * | Cable trays/conduits [3210 m]; Cable trays [9630 h] | 385,200 | 223,320 | XE405402 | 9630 | 4200 | 934 | 54 | 200 | 200 | C | LND | X | E | XE40 | 5402 | E | 54 | X | EL | LND | 5402 | URMA | 9630,00 |  |  | 27.8. |  | x |  |  | E-15-01-04 | m |  | UDF_G4 |  |  | 2011-03-20 |  | 2011-05-20 |  | 2500 | 2011-04-11 | 2011-06-09 | 2011-09-15 | 2011-05-23 | actual finish | UDF_G2 |  |
| XE915402 |  | CA54 SR5402 - Installation Earthing Foundations_E/I |  | 15d | 2011-05-14 A | 2011-05-31 A | XN205402 | 100% |  |  |  |  |  |  | TB26 - V - Construct-Winter partly * |  |  |  | XE915402 | 0 | 0 | 934 | 54 | 200 | 200 | C | LND | X | E | XE91 | 5402 | E | 54 | X | EA | LND | 5402 | URMA | 195 |  |  |  |  |  |  |  | E-16-07-17 |  |  |  |  |  | 2011-03-20 |  | 2011-08-30 |  |  |  |  | 2012-04-10 | 2011-05-23 |  | UDF_G2 |  |
| XE705402 |  | CA54 SR5402 - Install Lighting & Small Power |  | 30d | 2011-08-22 A | 2011-09-30 | XE405402, XP341610 FS+50d, P3E03S2 (other project), EE76510110 (other project), EE765402 (other project), E3E0935 (other project) |  | 30d | 2011-09-17 | 2011-10-21 | 176d | 74d |  | TB26 - V - Construct-Winter partly * | Cable Pulling [1200 m]; Lighting illuminates [110 pcs]; Lighting (iluminates) [1100 h]; Cable pulling [600 h] | 68,000 |  | XE705402 | 1700 | 0 | 934 | 54 | 200 | 200 | C | LND | X | E | XE70 | 5402 | E | 54 | X | EL | LND | 5402 | URMA | 1700,00 |  |  |  |  |  |  |  | E-16-03-01 |  |  |  |  |  | 2011-05-10 |  | 2012-01-31 |  |  |  |  | 2012-05-10 | 2011-08-15 |  | UDF_G2 |  |
| XE805402 |  | CA54 SR5402 - Install Heat Tracing |  | 50d | 2011-11-17 | 2012-03-09 | E3E1950 (other project), P3E19S (other project), XE705402 FF+12d, XR605402 |  |  |  |  | 107d | 24d |  | TB26 - V - Construct-Winter partly * | Electrical Heat Tracing [2600 m]; Electrical heat tracing [1300 h] | 52,000 |  | XE805402 | 1300 | 0 | 934 | 54 | 200 | 200 | C | LND | X | E | XE80 | 5402 | E | 54 | X | HT | LND | 5402 | URMA | 1300,00 |  |  |  |  |  |  |  | E-16-04-01 |  |  |  |  |  | 2011-06-20 |  | 2012-03-20 |  |  |  |  | 2012-06-30 | 2011-09-15 |  | UDF_G2 | 005 |
| XE505402 |  | CA54 SR5402 - Cable Pulling Electric |  | 100d | 2012-05-17 | 2012-09-12 | EE565402 (other project), XE501610 SS, XE411610, XE500C01, XE405402 |  |  |  |  | -148.5d | 0d |  | TB26 - V - Construct-Winter partly * | Cable Pulling [16000 m]; Cable pulling [8000 h] | 320,000 |  | XE505402 | 8000 | 0 | 934 | 54 | 200 | 200 | C | LND | X | E | XE50 | 5402 | E | 54 | X | EL | LND | 5402 | URMA | 8000,00 |  |  |  |  |  |  |  | E-16-01-01 | m |  |  |  |  | 2011-05-20 |  | 2012-02-10 |  | 16500 | 2011-07-19 | 2011-11-16 | 2012-07-01 | 2011-10-01 |  | UDF_G2 |  |

Notes:
- XC115402: P3 Activity Log Info: incl. Dewatering/Drainage
- XC155402: P3 Activity Log Info: 106 driven piles expected,20/d/machine
- XC205402: Current Status: 12.01.2011 (Oxana): die Ressourcen wurden nicht / verдndert.
- XC305402: P3 Activity Log Info: Clarification Prefab Catch Basins/pulling / pits / Current Status: 12.0.2011 (O. Siegel): nach Rьcksprache mit MO11 am 11 und / 12.Januar 11, wurde der 25-April-11 als Starttermin besprochen.
- XN715402: Scope: 09.02.2011: weight: 40 ton
- XR205402: Current Status: 10.03.2011 (O.Siegel): ENG ist noch nicht abgeschlossen. / Auf dem Piperack sind nur die HVAC-Rohre. Nach Absprache mit M. Siegel wurde / Startdatum fьr Piping Prefabrication auf Ende April 2011 gesetzt.
- XR405402: Current Status: 10.03.2011 (O.Siegel): ENG ist noch nicht abgeschlossen. / Auf dem Piperack sind nur die HVAC-Rohre. Nach Absprache mit M. Siegel wurde / Startdatum fьr Piping Prefabrication auf Ende April 2011 gesetzt.
- XE405402: UDF_PREDECESSOR: XN30, Piping 50%
- XE915402: UDF_PREDECESSOR: XN30, DEL XE40, DEL XE80, DEL XJ40, Civil 100%, Equipment 100%
- XE705402: UDF_PREDECESSOR: XE40, Civil 100%, HVAC ducts, Finishing works partly
- XE805402: UDF_PREDECESSOR: XR40, Piping 50% pressure tests
- XE505402: UDF_PREDECESSOR: XE40, XE50, DEL XE34

| ID | WBS | Activity | Type | Duration | Start | Finish | Predecessors | Complete | Remaining | Planned start | Planned finish | Total float | Free float | Constraint | Calendar | Resources | Cost | Actual cost | TB26 Ressource Budget | UDF_CONTRACT START DATE | UDF_CONTRACT FINISH DATE | UDF_CONTRACT ITEM | TB26 Semantics | TB26 Material Res Values | UDF_ELECTRICAL START | UDF_ELECTRICAL FINISH | UDF_CONTRACT FINISH DATE REV1 | UDF_CONTRACT START DATE REV1 | UDF_SAVE ACT ID | UDF_CHECK BASELINE | UDF_BUDGETED LABOR UNIT | UDF_ACTUAL LABOR UNIT | UDF_PREDECESSOR | UDF_INDICATOR | Department | Constr. Area | PMT-Area | PMT-Schedule Org | PMT-Phase | PMT-Respons. | WBS Phase | WBS Discipline | WBS Type of Work | WBS Objects | Russia WBS Discipline (Russia) | Russia Construction Area | Russia WBS Phase | IMS | UPT | Russia WBS Objects | Subcontractor | UDF_SELECT UPDATE PROGRESS | Type of Work | Inquiry/Order No | 4 week lookahead | UDF_CHECK RESOURCE DATES | UDF_Concrete | Zeigen/n. Zeigen | UDF_CONTRACT INDICATOR | UDF_CHECK CRITICAL PATH |
| --- | --- | --- | --- | --- | --- | --- | --- | --- | --- | --- | --- | --- | --- | --- | --- | --- | --- | --- | --- | --- | --- | --- | --- | --- | --- | --- | --- | --- | --- | --- | --- | --- | --- | --- | --- | --- | --- | --- | --- | --- | --- | --- | --- | --- | --- | --- | --- | --- | --- | --- | --- | --- | --- | --- | --- | --- | --- | --- | --- | --- |
|  | J | **Instrumentation** |  |  | 2011-07-04 | 2012-07-16 |  |  |  |  |  |  |  |  |  |  |  |  |  |  |  |  |  |  |  |  |  |  |  |  |  |  |  |  |  |  |  |  |  |  |  |  |  |  |  |  |  |  |  |  |  |  |  |  |  |  |  |  |  |  |
| XJ425402 |  | CA54 SR5402 - Install CableTrays Instrumentation |  | 47d | 2011-07-04 A | 2011-08-26 A | EJ46540210 (other project), XE405402 | 100% |  |  |  |  |  |  | TB26 - V - Construct-Winter partly * | Main cable trays [700 m]; Install Main Cable trays [2100 h] | 84,000 |  | 2100,00 | 2011-03-20 | 2011-05-20 | E-15-01-04 | m | 1655 | 2011-04-11 | 2011-06-09 | 2011-09-15 | 2011-05-23 | XJ425402 | x | 2100 | 0 | XE40, XJ32, Equipment 100%, Piping 50% | UDF_G2 | 934 | 54 | 200 | 200 | C | LND | X | J | XJ42 | 5402 | J | 54 | X | IN | LND | 5402 | URMA |  |  |  |  |  |  |  |  |  |
| XJ525402 |  | CA54 SR5402 - Pulling Instrument Cables |  | 50d | 2012-05-17 | 2012-07-16 | XE500C01, P3J17S1 (other project) FS+15d, XJ425402, P3J17S (other project), XE505402 SS |  |  |  |  | -97.5d | 0d |  | TB26 - V - Construct-Winter partly * | Multicore cables [4800 m]; Pull multicore cables [2400 h] | 96,000 |  | 2400,00 | 2011-03-20 | 2011-09-20 | E-17-04-17 | m | 3500 | 2011-07-09 | 2011-09-05 | 2012-03-30 | 2011-08-10 | XJ525402 |  | 2400 | 0 | XE40, XJ32, XJ52 | UDF_G2 | 934 | 54 | 200 | 200 | C | LND | X | J | XJ52 | 5402 | J | 54 | X | IN | LND | 5402 | URMA |  |  |  |  |  |  |  |  |  |
|  | W | **Painting** |  |  | 2011-10-07 | 2011-10-18 |  |  |  |  |  |  |  |  |  |  |  |  |  |  |  |  |  |  |  |  |  |  |  |  |  |  |  |  |  |  |  |  |  |  |  |  |  |  |  |  |  |  |  |  |  |  |  |  |  |  |  |  |  |  |
| XW505402 |  | CA54 SR5402 - Surf.Protection Piping |  | 10d | 2011-10-07 | 2011-10-18 | XR205402 FF+5d |  |  |  |  | -25d | 0d | as late as possible |  | Piping painting [10 sqm]; Piping painting [25 h] | 424.24 |  | 25,00 |  |  |  |  |  |  |  |  |  | XW505402 |  | 25 | 0 |  |  | 934 | 54 | 200 | 200 | C | LND | X | W | XW50 | 5402 | W | 54 | X | PA | LND | 5402 |  | 27.8. |  |  |  |  |  |  |  |  |
|  | V | **Insulation** |  |  | 2012-03-01 | 2012-05-18 |  |  |  |  |  |  |  |  |  |  |  |  |  |  |  |  |  |  |  |  |  |  |  |  |  |  |  |  |  |  |  |  |  |  |  |  |  |  |  |  |  |  |  |  |  |  |  |  |  |  |  |  |  |  |
| XV505402 |  | CA54 SR5402 - Insulation Piping |  | 60d | 2012-03-01 | 2012-05-18 | XE805402 FF+20d, XE805402 SS+20d |  |  |  |  | 83d | 98.5d |  | TB26 - T - Construct-Winter-3 (Dec/Jan/Feb free) * | Piping insulation [20 sqm]; Piping insulation [150 h] | 1,614.17 |  | 150,00 |  | 2012-04-30 | E-13-01 |  |  |  |  |  |  | XV505402 |  | 150 | 0 |  |  | 934 | 54 | 200 | 200 | C | LND | X | V | XV50 | 5402 | V | 54 | X | INS | LND | 5402 |  |  |  |  |  |  |  |  |  |  |
|  | 55 | **CA55 - Pipe Rack** |  |  | 2008-09-24 | 2012-08-14 |  |  |  |  |  |  |  |  |  |  |  |  |  |  |  |  |  |  |  |  |  |  |  |  |  |  |  |  |  |  |  |  |  |  |  |  |  |  |  |  |  |  |  |  |  |  |  |  |  |  |  |  |  |  |
|  | 0B | **General Activities** |  |  | 2012-07-27 | 2012-08-14 |  |  |  |  |  |  |  |  |  |  |  |  |  |  |  |  |  |  |  |  |  |  |  |  |  |  |  |  |  |  |  |  |  |  |  |  |  |  |  |  |  |  |  |  |  |  |  |  |  |  |  |  |  |  |
| X0105510 |  | CA55 General - Construction Completion | milestone | 0d | 2012-07-27 | 2012-07-27 | XR805501, XE705501, XE915501, XC705503, XC305501, XN205501, XJ525501, XC195501, XN405503, XN605502, XN405501, XE705502, XE915502, XN405502, XC605501, XR405501, XN605503, XN605501 |  |  |  |  | -26.5d | 18d |  | TB26 - 2 - Manuf and Delivy |  |  |  |  |  |  |  |  |  |  |  |  |  | X0105510 |  | 0 | 0 |  |  | 934 | 55 | 200 | 200 | C | LND | X | 0B | X010 | 5500 | 0 | 55 | X | MC | LND | 5500 |  |  | XNK |  |  |  |  |  |  |  |
| X0105500 |  | CA55 General - Mechanical Completion | milestone | 0d | 2012-08-14 | 2012-08-14 | XE705501, XJ525501, XE705502, XE505502 FF, XC605501, XE915501, XV505501 FF, XC705503 FF, XC605503, XR805502, X0105510, XE505501 FF, XE915502, XV505502 FF, XE505503 FF, XJ525503 FF, XJ525502, XV505503 FF, XC605502 |  |  |  |  | 10.5d | 137d |  | TB26 - 2 - Manuf and Delivy |  |  |  |  |  |  |  |  |  |  |  |  |  | X0105500 |  | 0 | 0 |  |  | 934 | 55 | 200 | 200 | C | LND | X | 0B | X010 | 5500 | 0 | 55 | X | MC | LND | 5500 |  |  | XNK |  |  |  |  |  |  |  |
|  | 01 | **CA5501** |  |  | 2008-09-24 | 2012-07-27 |  |  |  |  |  |  |  |  |  |  |  |  |  |  |  |  |  |  |  |  |  |  |  |  |  |  |  |  |  |  |  |  |  |  |  |  |  |  |  |  |  |  |  |  |  |  |  |  |  |  |  |  |  |  |
|  | C | **Civil Work** |  |  | 2008-09-24 | 2012-03-13 |  |  |  |  |  |  |  |  |  |  |  |  |  |  |  |  |  |  |  |  |  |  |  |  |  |  |  |  |  |  |  |  |  |  |  |  |  |  |  |  |  |  |  |  |  |  |  |  |  |  |  |  |  |  |
| XC115501 |  | CA55 SR5501 - Excavation&Surface Prep by U/I/O |  | 294d | 2008-09-24 A | 2009-09-30 A | XC111700 SS | 100% |  |  |  |  |  |  |  |  |  |  |  |  |  |  |  |  |  |  |  |  | XC115501 |  | 0 | 0 |  |  | 934 | 55 | 200 | 200 | C | UIO | X | C | XC11 | 5501 | C | 55 | X | CW | LND | 5501 | MO11 |  |  |  |  |  |  |  |  |  |
| XC11550105 |  | CA55 SR5501 - Excavation |  | 6d | 2010-05-15 A | 2010-05-21 A | XC11170005 SS+18d | 100% |  |  |  |  |  |  |  | Excavation [3450 cbm]; Excavation [1725 h] | 138,000 | 138,000 | 1725,00 |  |  |  |  |  |  |  |  |  | XC11550105 |  | 1725 | 1725 |  |  | 934 | 55 | 200 | 200 | C | MO02 | X | C | XC11 | 5501 | C | 10 | X | P | LND | 1010 | MO11 |  |  | 999 |  |  |  |  |  |  |
| XC11550110 |  | CA55 SR5501 - SubBase (Gravel/Geogrid) for Concrete |  | 11d | 2010-05-26 A | 2010-06-08 A | XC11550105 FS+3d | 100% |  | 2010-05-26 | 2010-06-07 |  |  |  |  | Sub Base for Concrete/Paving&Roads (Gravel) [500 cbm]; Subbase for Concrete [500 h] | 50,000 | 20,000 | 500,00 |  |  |  |  |  |  |  |  |  | XC11550110 |  | 500 | 500 |  |  | 934 | 55 | 200 | 200 | C | MO02 | X | C | XC11 | 5501 | C | 10 | X | P | LND | 1010 | MO11 |  |  | 999 |  |  |  |  |  |  |
| XC155501 |  | CA55 SR5501 - Piling |  | 5d | 2010-09-21 A | 2010-09-25 A | EC155501 (other project) FS+8d, XC11550110 FS+7d, XC11550105 FS+4d, XC115501, XC155502, F2910, XC155402 | 100% |  |  |  |  |  |  |  | Piles driven [24 pcs]; Piles driven [180 h] | 7,200 | 7,200 | 180,00 |  |  |  |  |  |  |  |  |  | XC155501 |  | 180 | 180 |  |  | 934 | 55 | 200 | 200 | C | MO02 | X | C | XC15 | 5501 | C | 55 | X | P | LND | 5501 | MO11 |  |  |  |  |  |  |  |  |  |
| XC205501 |  | CA55 SR5501 - Concrete Works |  | 43d | 2010-10-30 A | 2011-02-02 A | XC205502 FF+7d, EC45550105 (other project), XC205401 SS+15d, EC285501 (other project) FS+20d, XC155501 | 100% |  |  |  |  |  |  | TB26 - V - Construct-Winter partly * | Concrete works [80 cbm]; Concrete works [2400 h] | 96,000 | 96,000 | 2400,00 |  |  |  |  |  |  |  |  |  | XC205501 |  | 2400 | 2400 |  |  | 934 | 55 | 200 | 200 | C | CiC | X | C | XC20 | 5501 | C | 55 | X | mis | LND | 5501 | MO11 |  |  |  | x |  |  |  |  |  |
| XC195501 |  | CA55 SR5501 - Backfill |  | 30d | 2011-08-15 A | 2011-11-09 | XC915501 FF+10d, XC305501 FF+10d |  | 19d | 2011-08-15 | 2011-09-17 | 88d | 0d |  | TB26 - T - Construct-Winter-3 (Dec/Jan/Feb free) * | Backfill & Compaction [2300 cbm]; Backfill & Compaction [3450 h] | 207,000 | 75,900 | 3450,00 |  |  |  |  |  |  |  |  |  | XC195501 |  | 3450 | 0 |  |  | 934 | 55 | 200 | 200 | C | CiC | X | C | XC19 | 5501 | C | 55 | X | mis | LND | 5501 | MO11 | 27.8. |  |  |  | ok |  |  |  |  |
| XC305501 |  | CA55 SR5501 - UG Installation (incl. Precast Manholes) |  | 9d | 2011-10-17 | 2011-10-26 | P3R02AS1 (other project), XC300C00, XC310C00, XC205501 FS-10d, P3R02BS (other project), EC305501 (other project) FS+20d, ER445501 (other project), P3R02S1 (other project), XC305503 SS |  |  |  |  | -13d | 0d |  | TB26 - V - Construct-Winter partly * |  |  |  |  |  |  |  |  |  |  |  |  |  | XC305501 |  | 0 | 0 |  |  | 934 | 55 | 200 | 200 | C | CiC | X | C | XC30 | 5501 | C | 55 | X | mis | LND | 5501 |  | 27.8. |  |  |  |  | 1 |  |  |  |
| XC605501 |  | CA55 SR5501 - Paving |  | 20d | 2011-11-10 | 2012-03-13 | XC195501 |  |  |  |  | 88d | 0d |  | TB26 - T - Construct-Winter-3 (Dec/Jan/Feb free) * | Gravel [430 sqm]; Gravel [22 h] | 824.08 |  | 22,00 |  |  |  |  |  |  |  |  |  | XC605501 |  | 22 | 0 |  |  | 934 | 55 | 200 | 200 | C | CiC | X | C | XC60 | 5501 | C | 55 | X | PV | LND | 5501 | MO11 |  |  |  |  |  | 1 |  |  |  |
|  | N | **Structural Steel** |  |  | 2011-02-01 | 2011-09-15 |  |  |  |  |  |  |  |  |  |  |  |  |  |  |  |  |  |  |  |  |  |  |  |  |  |  |  |  |  |  |  |  |  |  |  |  |  |  |  |  |  |  |  |  |  |  |  |  |  |  |  |  |  |  |
| XN705501 |  | CA55 SR5501 - KMD Assy Drawings | milestone | 0d | 2011-02-01 A | 2011-02-01 A |  | 100% |  |  |  |  |  | finish on 2011-01-22 |  |  |  |  | 22t |  |  |  |  |  |  |  |  |  | XN705501 | x | 0 | 0 |  |  | 934 | 55 | 200 | 200 | C | LND | X | N | XN05 | 5501 | N | 55 | X | PR | LND | 5501 |  |  | XNK |  |  |  |  | KMD |  |  |
| XN715501 |  | CA55 SR5501 - Steel Deliveries | milestone | 0d | 2011-02-01 A | 2011-02-01 A |  | 100% |  |  |  |  |  | finish on 2011-01-31 | TB26 - 3 - Construction Normal 7days * CA17 |  |  |  | 22t |  |  |  |  |  |  |  |  |  | XN715501 |  | 0 | 0 |  |  | 934 | 55 | 200 | 200 | C | LND | X | N | XN06 | 5501 | N | 55 | X | PR | LND | 5501 |  |  | XNK |  |  |  |  | SD |  |  |
| XN205501 |  | CA55 SR5501 - Installation Steel Structure |  | 75d | 2011-02-21 A | 2011-05-31 A | P3N01IN (other project), XN705501, EN685501 (other project), XN715501 FS+10d, XC915501, P3N012D (other project) FS+10d | 100% |  |  |  |  |  |  | TB26 - V - Construct-Winter partly * | Piperacks, Main Structures [17 t]; Piperacks, Main structures [722.5 h] | 28,900 | 28,900 | 722,50 |  |  | E-04-32 | t |  |  |  |  |  | XN205501 |  | 722,5 | 722,5 |  |  | 934 | 55 | 200 | 200 | C | LND | X | N | XN20 | 5501 | N | 55 | X | PR | LND | 5501 | ChSK |  | XNK |  | x |  |  |  |  |  |
| XN405501 |  | CA55 SR5501 - Install Railings,Ladders,etc. |  | 10d | 2011-08-22 A | 2011-09-15 | XN205501, XE405501 |  | 17d | 2011-08-22 | 2011-09-01 | 236d | 258.5d | start on or after 2011-08-22 |  | Ladders & platforms [1 t]; Ladders & platforms [100 h] | 362.15 |  | 100,00 |  |  |  |  |  |  |  |  |  | XN405501 | x | 100 | 0 |  |  | 934 | 55 | 200 | 200 | C | LND | X | N | XN40 | 5501 | N | 55 | X | SS | LND | 5501 | ChSK | 27.8. | XNK |  |  | ok |  |  | UDF_G4 | Check Roof - Cladding |

Notes:
- XW505402: P3 Activity Log Info: Clarification Surface Protection during Prefab
- XC115501: P3 Activity Log Info: incl. Dewatering/Drainage
- XC155501: P3 Activity Log Info: 108 driven piles expected,20/d/machine
- XC205501: Current Status: 12.01.2011 (Oxana): die Ressourcen wurden geдndert / angepasst. Ursprьnglich war die Summe aus Actual und Remaining-Daten grцЯer als / das Budgetet-Daten.
- XC305501: P3 Activity Log Info: Clarification Prefab Catch Basins/pulling / pits / Current Status: 12.0.2011 (O. Siegel): nach Rьcksprache mit MO11 am 11 und / 12.Januar 11, wurde der 25-April-11 als Starttermin besprochen.
- XN715501: Scope: 09.02.2011: weight: 17 ton
- XN205501: Current Status: 19.02.2011 (O.Siegel): die Baufreiheit von MO11 an CSK / wurde am 16.02.2011 ьbergeben.

| ID | WBS | Activity | Duration | Start | Finish | Predecessors | Complete | Remaining | Planned start | Planned finish | Total float | Free float | Constraint | Calendar | Resources | Cost | Actual cost | TB26 Ressource Budget | UDF_SAVE ACT ID | UDF_BUDGETED LABOR UNIT | UDF_ACTUAL LABOR UNIT | UDF_COMMENTS_0827 | Department | Constr. Area | PMT-Area | PMT-Schedule Org | PMT-Phase | PMT-Respons. | WBS Phase | WBS Discipline | WBS Type of Work | WBS Objects | Russia WBS Discipline (Russia) | Russia Construction Area | Russia WBS Phase | IMS | UPT | Russia WBS Objects | 4 week lookahead | UDF_CONTRACT START DATE | UDF_CONTRACT ITEM | UDF_PLANNED START | UDF_CONTRACT FINISH DATE | UDF_PLANNED FINISH | Subcontractor | UDF_CONTRACT INDICATOR | TB26 Semantics | TB26 Material Res Values | UDF_ELECTRICAL START | UDF_ELECTRICAL FINISH | UDF_ELECTRICAL SEQUENCE | UDF_CONTRACT FINISH DATE REV1 | UDF_CONTRACT START DATE REV1 | UDF_CHECK BASELINE | UDF_INDICATOR | UDF_SELECT UPDATE PROGRESS | UDF_CHECK RESOURCE DATES | UDF_Vendor Representatives | Comments |
| --- | --- | --- | --- | --- | --- | --- | --- | --- | --- | --- | --- | --- | --- | --- | --- | --- | --- | --- | --- | --- | --- | --- | --- | --- | --- | --- | --- | --- | --- | --- | --- | --- | --- | --- | --- | --- | --- | --- | --- | --- | --- | --- | --- | --- | --- | --- | --- | --- | --- | --- | --- | --- | --- | --- | --- | --- | --- | --- | --- |
|  | H | **HVAC** |  |  |  |  |  |  |  |  |  |  |  |  |  |  |  |  |  |  |  |  |  |  |  |  |  |  |  |  |  |  |  |  |  |  |  |  |  |  |  |  |  |  |  |  |  |  |  |  |  |  |  |  |  |  |  |  |  |
|  | U | **Package Units** |  |  |  |  |  |  |  |  |  |  |  |  |  |  |  |  |  |  |  |  |  |  |  |  |  |  |  |  |  |  |  |  |  |  |  |  |  |  |  |  |  |  |  |  |  |  |  |  |  |  |  |  |  |  |  |  |  |
|  | B | **Mechanical - Stationary Equipment** |  |  |  |  |  |  |  |  |  |  |  |  |  |  |  |  |  |  |  |  |  |  |  |  |  |  |  |  |  |  |  |  |  |  |  |  |  |  |  |  |  |  |  |  |  |  |  |  |  |  |  |  |  |  |  |  |  |
|  | M | **Mechanical - Rotating Equipment** |  |  |  |  |  |  |  |  |  |  |  |  |  |  |  |  |  |  |  |  |  |  |  |  |  |  |  |  |  |  |  |  |  |  |  |  |  |  |  |  |  |  |  |  |  |  |  |  |  |  |  |  |  |  |  |  |  |
|  | R | **Piping** |  | 2011-09-23 | 2012-03-29 |  |  |  |  |  |  |  |  |  |  |  |  |  |  |  |  |  |  |  |  |  |  |  |  |  |  |  |  |  |  |  |  |  |  |  |  |  |  |  |  |  |  |  |  |  |  |  |  |  |  |  |  |  |  |
| XR205501 |  | CA55 SR5501 - Piping Prefabrication | 10d | 2011-09-23 | 2011-10-04 | ER495501 (other project) FS+20d |  |  |  |  | -18d | 0d | as late as possible |  | A/G piping prefabrication [20 Fpi]; A/G Piping (Prefab) [75 h] | 92.39 |  | 75,00 | XR205501 | 75 | 0 | Start 19.09.11 | 934 | 55 | 200 | 200 | C | LND | X | R | XR20 | 5501 | R | 55 | X | PRP | LND | 5501 | x |  |  |  |  |  |  |  |  |  |  |  |  |  |  |  |  |  |  |  |  |
| XR405501 |  | CA55 SR5501 - Piping Installation | 10d | 2011-10-11 | 2011-10-21 | ER475501 (other project) FS-20d, XN205501, IMS-C-000190 FF, XR205501 SS+5d, XW505501, XN205502 FS+10d, XN205503 |  |  |  |  | -18d | 62d |  | TB26 - V - Construct-Winter partly * | A/G piping field installation [50 Fpi]; A/G Piping (Field) [312.5 h] | 325.2 |  | 312,50 | XR405501 | 312,5 | 0 |  | 934 | 55 | 200 | 200 | C | LND | X | R | XR40 | 5501 | R | 55 | X | PI | LND | 5501 |  | 2011-01-20 | E-06-03-12 | 2011-02-28 |  |  |  |  |  |  |  |  |  |  |  |  |  |  |  |  |  |
| XR605501 |  | CA55 SR5501 - Piping Pressure Tests | 15d | 2012-03-01 | 2012-03-22 | XR405501, XR605503 SS, X0300020, XR605502 SS |  |  |  |  | -44d | 0d |  | TB26 - T - Construct-Winter-3 (Dec/Jan/Feb free) * |  |  |  | 7 | XR605501 | 0 | 0 |  | 934 | 55 | 200 | 200 | C | LND | X | R | XR60 | 5501 | R | 55 | X | HY | LND | 5501 |  |  | E-06-03-12 |  |  |  |  |  |  |  |  |  |  |  |  |  |  |  |  |  |  |
| XR805501 |  | CA55 SR5501 - Piping Reinstatement | 10d | 2012-03-16 | 2012-03-29 | XR605501 FF+5d, IMS-C-000360 FF |  |  |  |  | 76d | 98.5d |  | TB26 - V - Construct-Winter partly * |  |  |  | 3 | XR805501 | 0 | 0 |  | 934 | 55 | 200 | 200 | C | LND | X | R | XR80 | 5501 | R | 55 | X | PI | LND | 5501 |  |  | E-06-03-12 |  | 2011-07-30 | 2011-09-06 |  |  |  |  |  |  |  |  |  |  |  |  |  |  |  |
|  | E | **Electrical** |  | 2010-10-30 | 2012-07-27 |  |  |  |  |  |  |  |  |  |  |  |  |  |  |  |  |  |  |  |  |  |  |  |  |  |  |  |  |  |  |  |  |  |  |  |  |  |  |  |  |  |  |  |  |  |  |  |  |  |  |  |  |  |  |
| XC915501 |  | CA55 SR5501 - Installation Earthing Foundations_CIVIL | 41d | 2010-10-30 A | 2011-01-31 A | EE905501 (other project), XC205501 FF | 100% |  |  |  |  |  |  | TB26 - V - Construct-Winter partly * | Grounding & Lightning [120 pcs]; Grounding & Lightning [1350 h] | 54,000 | 54,000 | 1350,00 | XC915501 | 1350 | 1350 |  | 934 | 55 | 200 | 200 | C | LND | X | C | XE91 | 5501 | C | 55 | X | EA | LND | 5501 |  | 2011-03-20 | E-16-07-17 |  | 2011-08-30 |  | MO11 |  |  |  |  |  |  |  |  |  |  |  |  |  |  |
| XE405501 |  | CA55 SR5501 - Install Cable Trays | 47d | 2011-05-23 A | 2011-07-30 A | EE46550110 (other project), XN205501, P3E16S (other project) | 100% |  | 2011-05-23 | 2011-07-16 |  |  | start on or after 2011-05-23 | TB26 - V - Construct-Winter partly * | Cable trays/conduits [880 m]; Cable trays [2640 h] | 105,600 | 15,000 | 2640,00 | XE405501 | 2640 | 375 |  | 934 | 55 | 200 | 200 | C | LND | X | E | XE40 | 5501 | E | 55 | X | EL | LND | 5501 |  | 2011-03-25 | E-15-01-05 |  | 2011-06-30 |  | URMA | UDF_G4 | m | 1300 | 2011-04-29 | 2011-06-17 | Plot plan | 2011-09-20 | 2011-05-23 | x | UDF_G2 |  |  |  |  |
| XE915501 |  | CA55 SR5501 - Installation Earthing Foundations_E/I | 17d | 2011-06-06 A | 2011-06-21 A | XE405501, XN205501, XJ425501 | 100% |  | 2011-06-06 | 2011-06-25 |  |  |  | TB26 - V - Construct-Winter partly * |  |  |  | 135 | XE915501 | 0 | 0 |  | 934 | 55 | 200 | 200 | C | LND | X | E | XE91 | 5501 | E | 55 | X | EA | LND | 5501 |  | 2011-03-20 | E-16-07-17 |  | 2011-08-30 |  | URMA |  |  |  |  |  |  | 2012-04-10 | 2011-05-23 |  | UDF_G2 |  |  |  |  |
| XE705501 |  | CA55 SR5501 - Install Lighting & Small Power | 25d | 2011-08-23 A | 2011-09-20 | P3E03S2 (other project), EE76510110 (other project), EE765501 (other project), XE405501, P3E09S (other project), XP341610 FS+50d |  | 21d |  |  | 185d | 142d |  | TB26 - V - Construct-Winter partly * | Cable Pulling [800 m]; Lighting illuminates [80 pcs]; Cable pulling [400 h]; Lighting (iluminates) [800 h] | 48,000 | 7,680 | 1200,00 | XE705501 | 1200 | 0 |  | 934 | 55 | 200 | 200 | C | LND | X | E | XE70 | 5501 | E | 55 | X | EL | LND | 5501 |  | 2011-05-10 | E-16-03-01 |  | 2012-01-31 |  | URMA |  |  |  |  |  |  | 2012-05-10 | 2011-08-15 |  | UDF_G2 | 27.8. | ok |  |  |
| XE805501 |  | CA55 SR5501 - Install Heat Tracing | 50d | 2012-03-23 | 2012-05-24 | XE705501 FF+12d, E3E1950 (other project), P3E19S (other project), XR405501, XR605501 |  |  |  |  | 48d | 0d |  | TB26 - V - Construct-Winter partly * | Electrical Heat Tracing [2200 m]; Electrical heat tracing [1100 h] | 44,000 |  | 1100,00 | XE805501 | 1100 | 0 |  | 934 | 55 | 200 | 200 | C | LND | X | E | XE80 | 5501 | E | 55 | X | HT | LND | 5501 |  | 2011-06-20 | E-16-04-01 |  | 2012-03-20 |  | URMA |  |  |  |  |  |  | 2012-06-30 | 2011-09-15 |  | UDF_G2 | 27.8. |  | 005 |  |
| XE505501 |  | CA55 SR5501 - Cable Pulling Electric | 50d | 2012-05-29 | 2012-07-27 | XE405501, P3E15AS (other project), P3E15BS (other project) FF+20d, P3E15CS (other project) FF+20d, XE500C01, EE565501 (other project), XE505402 SS+10d |  |  |  |  | -148.5d | 0d |  | TB26 - V - Construct-Winter partly * | Cable Pulling [14000 m]; Cable pulling [7000 h] | 280,000 |  | 7000,00 | XE505501 | 7000 | 0 |  | 934 | 55 | 200 | 200 | C | LND | X | E | XE50 | 5501 | E | 55 | X | EL | LND | 5501 |  | 2011-05-20 | E-16-01-01 |  | 2012-02-10 |  | URMA |  | m | 14500 | 2011-07-19 | 2011-09-14 | Plot plan | 2012-07-01 | 2011-10-01 |  | UDF_G2 |  |  |  |  |
|  | J | **Instrumentation** |  | 2011-07-04 | 2012-07-27 |  |  |  |  |  |  |  |  |  |  |  |  |  |  |  |  |  |  |  |  |  |  |  |  |  |  |  |  |  |  |  |  |  |  |  |  |  |  |  |  |  |  |  |  |  |  |  |  |  |  |  |  |  |  |
| XJ425501 |  | CA55 SR5501 - Install CableTrays Instrumentation | 47d | 2011-07-04 A | 2011-08-26 A | XR405501 FF+10d, EJ46550110 (other project), XE705501 FF, XE405501 FF | 100% |  |  |  |  |  |  | TB26 - V - Construct-Winter partly * | Main cable trays [270 m]; Install Main Cable trays [810 h] | 32,400 |  | 810,00 | XJ425501 | 810 | 0 |  | 934 | 55 | 200 | 200 | C | LND | X | J | XJ42 | 5501 | J | 55 | X | IN | LND | 5501 |  | 2011-03-25 | E-15-01-05 |  | 2011-06-30 |  | URMA |  | m | 850 | 2011-04-29 | 2011-06-17 | Plot plan | 2011-09-20 | 2011-05-23 | x | UDF_G2 |  |  |  | boarding needed |
| XJ525501 |  | CA55 SR5501 - Pulling Instrument Cables | 50d | 2012-05-29 | 2012-07-27 | XJ425501, XJ525402 SS, XE505501 SS, XE500C01, XJ520C00 SS, P3J17S1 (other project) |  |  |  |  | -82.5d | 0d |  | TB26 - V - Construct-Winter partly * | Multicore cables [3400 m]; Pull multicore cables [1700 h] | 68,000 |  | 1700,00 | XJ525501 | 1700 | 0 |  | 934 | 55 | 200 | 200 | C | LND | X | J | XJ52 | 5501 | J | 55 | X | IN | LND | 5501 |  | 2011-03-20 | E-17-04-17 |  | 2011-09-20 |  | URMA |  | m | 2500 | 2011-07-23 | 2011-09-19 |  | 2012-03-30 | 2011-08-10 |  | UDF_G2 |  |  |  |  |
|  | S | **Safety & Environment** |  |  |  |  |  |  |  |  |  |  |  |  |  |  |  |  |  |  |  |  |  |  |  |  |  |  |  |  |  |  |  |  |  |  |  |  |  |  |  |  |  |  |  |  |  |  |  |  |  |  |  |  |  |  |  |  |  |
|  | W | **Painting** |  | 2011-09-29 | 2011-10-10 |  |  |  |  |  |  |  |  |  |  |  |  |  |  |  |  |  |  |  |  |  |  |  |  |  |  |  |  |  |  |  |  |  |  |  |  |  |  |  |  |  |  |  |  |  |  |  |  |  |  |  |  |  |  |
| XW505501 |  | CA55 SR5501 - Surf.Protection Piping | 10d | 2011-09-29 | 2011-10-10 | XR205501 FF+5d |  |  |  |  | -18d | 0d | as late as possible |  | Piping painting [10 sqm]; Piping painting [25 h] | 753.87 |  | 25,00 | XW505501 | 25 | 0 |  | 934 | 55 | 200 | 200 | C | LND | X | W | XW50 | 5501 | W | 55 | X | PA | LND | 5501 |  |  |  |  |  |  |  |  |  |  |  |  |  |  |  |  |  |  |  |  |  |
|  | V | **Insulation** |  | 2012-04-18 | 2012-06-29 |  |  |  |  |  |  |  |  |  |  |  |  |  |  |  |  |  |  |  |  |  |  |  |  |  |  |  |  |  |  |  |  |  |  |  |  |  |  |  |  |  |  |  |  |  |  |  |  |  |  |  |  |  |  |
| XV505501 |  | CA55 SR5501 - Insulation Piping | 60d | 2012-04-18 | 2012-06-29 | XE805501 FF+20d, XE805501 SS+20d |  |  |  |  | 48d | 38.5d |  | TB26 - T - Construct-Winter-3 (Dec/Jan/Feb free) * | Piping insulation [100 sqm]; Piping insulation [750 h] | 2,861.75 |  | 750,00 | XV505501 | 750 | 0 |  | 934 | 55 | 200 | 200 | C | LND | X | V | XV50 | 5501 | V | 55 | X | INS | LND | 5501 |  |  | E-13-01 |  | 2012-04-30 |  |  |  |  |  |  |  |  |  |  |  |  |  |  |  |  |

Notes:
- XR205501: Current Status: 10.03.2011 (O.Siegel): Material nocht nicht ausreichend / vorhanden auf der Baustelle. Nach Absprache mit M. Siegel wurde Startdatum / fьr Piping Prefabrication auf Anfang April 2011 gesetzt.
- XR405501: Current Status: 10.03.2011 (O.Siegel): Material nocht nicht ausreichend / vorhanden auf der Baustelle. Nach Absprache mit M. Siegel wurde Startdatum / fьr Piping Prefabrication auf Anfang April 2011 gesetzt.
- XE405501: Current Status: 04.04.2011 (O.Siegel): die Verlinkung zu Piping / Installation SR5501 gelцscht: in der SR5501 wird kein Piping montiert. / UDF_PREDECESSOR: XN30, Piping 50%
- XE915501: UDF_PREDECESSOR: XN30, DEL XE40, DEL XE80, DEL XJ40, Civil 100%, Equipment 100%
- XE705501: UDF_PREDECESSOR: XE40, Civil 100%, HVAC ducts, Finishing works partly
- XE805501: UDF_PREDECESSOR: XR40, Piping 50% pressure tests
- XE505501: P3 Activity Log Info: Lag between CA 54 SS 10 days - same like CA 51 - CA54 / UDF_PREDECESSOR: XE40, XE50, DEL XE34
- XJ425501: UDF_PREDECESSOR: XE40, XJ32, Equipment 100%, Piping 50%
- XJ525501: UDF_PREDECESSOR: XE40, XJ32, XJ52
- XW505501: P3 Activity Log Info: Clarification Surface Protection during Prefab

| ID | WBS | Activity | Type | Duration | Start | Finish | Predecessors | Complete | Remaining | Planned start | Planned finish | Total float | Free float | Constraint | Calendar | Resources | Cost | Actual cost | UDF_SAVE ACT ID | UDF_BUDGETED LABOR UNIT | UDF_ACTUAL LABOR UNIT | Department | Constr. Area | PMT-Area | PMT-Schedule Org | PMT-Phase | PMT-Respons. | WBS Phase | WBS Discipline | WBS Type of Work | WBS Objects | Russia WBS Discipline (Russia) | Russia Construction Area | Russia WBS Phase | IMS | UPT | Russia WBS Objects | Subcontractor | TB26 Ressource Budget | Inquiry/Order No | UDF_SELECT UPDATE PROGRESS | UDF_CHECK RESOURCE DATES | UDF_Concrete | UDF_CHECK BASELINE | Type of Work | Zeigen/n. Zeigen | UDF_CONTRACT ITEM | UDF_CONTRACT INDICATOR | TB26 Semantics | 4 week lookahead | Comments | UDF_COMMENTS_0827 | UDF_CONTRACT START DATE | UDF_PLANNED START | UDF_CONTRACT FINISH DATE | UDF_PLANNED FINISH | TB26 Material Res Values | UDF_ELECTRICAL START | UDF_ELECTRICAL FINISH | UDF_ELECTRICAL SEQUENCE | UDF_CONTRACT FINISH DATE REV1 | UDF_CONTRACT START DATE REV1 | UDF_INDICATOR | UDF_Vendor Representatives |
| --- | --- | --- | --- | --- | --- | --- | --- | --- | --- | --- | --- | --- | --- | --- | --- | --- | --- | --- | --- | --- | --- | --- | --- | --- | --- | --- | --- | --- | --- | --- | --- | --- | --- | --- | --- | --- | --- | --- | --- | --- | --- | --- | --- | --- | --- | --- | --- | --- | --- | --- | --- | --- | --- | --- | --- | --- | --- | --- | --- | --- | --- | --- | --- | --- |
|  | 02 | **CA5502** |  |  | 2008-09-24 | 2012-08-02 |  |  |  |  |  |  |  |  |  |  |  |  |  |  |  |  |  |  |  |  |  |  |  |  |  |  |  |  |  |  |  |  |  |  |  |  |  |  |  |  |  |  |  |  |  |  |  |  |  |  |  |  |  |  |  |  |  |  |
|  | C | **Civil Work** |  |  | 2008-09-24 | 2012-03-23 |  |  |  |  |  |  |  |  |  |  |  |  |  |  |  |  |  |  |  |  |  |  |  |  |  |  |  |  |  |  |  |  |  |  |  |  |  |  |  |  |  |  |  |  |  |  |  |  |  |  |  |  |  |  |  |  |  |  |
| XC115502 |  | CA55 SR5502 - Excavation&Surface Prep by U/I/O |  | 294d | 2008-09-24 A | 2009-09-30 A | XC115501 SS | 100% |  |  |  |  |  |  |  |  |  |  | XC115502 | 0 | 0 | 934 | 55 | 200 | 200 | C | UIO | X | C | XC11 | 5502 | C | 55 | X | CW | LND | 5502 | MO11 |  |  |  |  |  |  |  |  |  |  |  |  |  |  |  |  |  |  |  |  |  |  |  |  |  |  |
| XC11550205 |  | CA55 SR5502 - Excavation |  | 8d | 2010-05-18 A | 2010-05-26 A | XC11550105 SS+2d | 100% |  |  |  |  |  |  |  | Excavation [7450 cbm]; Excavation [3725 h] | 298,000 | 298,000 | XC11550205 | 3725 | 3725 | 934 | 55 | 200 | 200 | C | MO02 | X | C | XC11 | 5502 | C | 10 | X | P | LND | 1010 | MO11 | 3725,00 | 999 |  |  |  |  |  |  |  |  |  |  |  |  |  |  |  |  |  |  |  |  |  |  |  |  |
| XC11550210 |  | CA55 SR5502 - SubBase (Gravel/Geogrid) for Concrete |  | 9d | 2010-05-28 A | 2010-06-08 A | XC11550205 | 100% |  | 2010-05-28 | 2010-06-07 |  |  |  |  | Sub Base for Concrete/Paving&Roads (Gravel) [600 cbm]; Subbase for Concrete [600 h] | 60,000 | 20,000 | XC11550210 | 600 | 600 | 934 | 55 | 200 | 200 | C | MO02 | X | C | XC11 | 5502 | C | 10 | X | P | LND | 1010 | MO11 | 600,00 | 999 |  |  |  |  |  |  |  |  |  |  |  |  |  |  |  |  |  |  |  |  |  |  |  |  |
| XC155502 |  | CA55 SR5502 - Piling |  | 84d | 2010-06-11 A | 2010-09-16 A | XC11550210, XC155503 SS+3d, EC155502 (other project) FS+8d, XC115502, XC11550205 FS+4d, F2910 | 100% |  |  |  |  |  |  |  | Piles driven [96 pcs]; Piles driven [720 h] | 28,800 | 28,800 | XC155502 | 720 | 720 | 934 | 55 | 200 | 200 | C | MO02 | X | C | XC15 | 5502 | C | 55 | X | P | LND | 5502 | MO11 | 720,00 |  |  |  |  |  |  |  |  |  |  |  |  |  |  |  |  |  |  |  |  |  |  |  |  |  |
| XC205502 |  | CA55 SR5502 - Concrete Works |  | 48d | 2010-10-11 A | 2010-12-31 A | P3C02D3 (other project) FF, EC285502 (other project) FS+20d, XC155502, EC45550205 (other project) | 100% |  | 2010-10-11 | 2010-12-29 |  |  |  | TB26 - V - Construct-Winter partly * | Concrete works [180 cbm]; Concrete works [5400 h] | 216,000 | 216,000 | XC205502 | 5400 | 5400 | 934 | 55 | 200 | 200 | C | CiC | X | C | XC20 | 5502 | C | 55 | X | mis | LND | 5502 | MO11 | 5400,00 |  |  |  |  |  |  |  |  |  |  |  |  |  |  |  |  |  |  |  |  |  |  |  |  |  |
| XC195502 |  | CA55 SR5502 - Backfill |  | 22d | 2011-08-09 A | 2011-09-02 | IMS-C-000040 FF, XC915502 FF |  | 6d |  |  | 186d | 59d | start on or after 2011-08-08 | TB26 - T - Construct-Winter-3 (Dec/Jan/Feb free) * | Backfill & Compaction [3100 cbm]; Backfill & Compaction [4650 h] | 279,000 | 148,800 | XC195502 | 4650 | 0 | 934 | 55 | 200 | 200 | C | CiC | X | C | XC19 | 5502 | C | 55 | X | mis | LND | 5502 | MO11 | 4650,00 |  | 27.8. | x |  |  |  |  |  |  |  |  |  |  |  |  |  |  |  |  |  |  |  |  |  |  |
| XC305502 |  | CA55 SR5502 - UG Installation (incl. Precast Manholes) |  | 35d | 2011-10-17 | 2011-12-12 | P3R02BS (other project), XC205502 SS+12d, ER445502 (other project), EC305502 (other project) FS+20d, P3R02AS1 (other project), P3R02S1 (other project), XC300C00, XC310C00, XC305503 SS |  |  |  |  | -13d | 33d |  | TB26 - V - Construct-Winter partly * |  |  |  | XC305502 | 0 | 0 | 934 | 55 | 200 | 200 | C | CiC | X | C | XC30 | 5502 | C | 55 | X | mis | LND | 5502 |  |  |  | 27.8. |  | 1 |  |  |  |  |  |  |  |  |  |  |  |  |  |  |  |  |  |  |  |  |  |
| XC605502 |  | CA55 SR5502 - Paving |  | 25d | 2011-11-16 | 2012-03-23 | XN205502, XC195502, XC605501 SS+3d |  |  |  |  | 127d | 0d |  | TB26 - T - Construct-Winter-3 (Dec/Jan/Feb free) * | Gravel [380 sqm]; Gravel [19 h] | 2,579.42 |  | XC605502 | 19 | 0 | 934 | 55 | 200 | 200 | C | CiC | X | C | XC60 | 5502 | C | 55 | X | PV | LND | 5502 | MO11 | 19,00 |  |  |  | 1 |  |  |  |  |  |  |  |  |  |  |  |  |  |  |  |  |  |  |  |  |  |
|  | N | **Structural Steel** |  |  | 2011-02-01 | 2011-09-28 |  |  |  |  |  |  |  |  |  |  |  |  |  |  |  |  |  |  |  |  |  |  |  |  |  |  |  |  |  |  |  |  |  |  |  |  |  |  |  |  |  |  |  |  |  |  |  |  |  |  |  |  |  |  |  |  |  |  |
| XN705502 |  | CA55 SR5502 - KMD Assy Drawings | milestone | 0d | 2011-02-01 A | 2011-02-01 A |  | 100% |  |  |  |  |  | finish on 2011-01-31 |  |  |  |  | XN705502 | 0 | 0 | 934 | 55 | 200 | 200 | C | LND | X | N | XN05 | 5502 | N | 55 | X | PR | LND | 5502 |  | 22t |  |  |  |  | x | XNK | KMD |  |  |  |  |  |  |  |  |  |  |  |  |  |  |  |  |  |  |
| XN715502 |  | CA52 SR5502 - Steel Deliveries | milestone | 0d | 2011-02-04 A | 2011-02-04 A |  | 100% |  |  |  |  |  | finish on 2011-02-04 | TB26 - 3 - Construction Normal 7days * CA17 |  |  |  | XN715502 | 0 | 0 | 934 | 55 | 200 | 200 | C | LND | X | N | XN06 | 5502 | N | 55 | X | PR | LND | 5502 |  | 22t |  |  |  |  |  | XNK | SD |  |  |  |  |  |  |  |  |  |  |  |  |  |  |  |  |  |  |
| XN205502 |  | CA55 SR5502 - Installation Steel Structure |  | 191d | 2011-02-21 A | 2011-09-28 | XN715502 FS+10d, P3N012D (other project) FS+10d, XC205502 SS+30d, EN685502 (other project), XN205501 SS-5d, XN705502, P3N01LN (other project), XC915502 |  | 15d | 2011-02-21 | 2011-10-06 | -18d | 0d |  |  | Piperacks, Main Structures [50 t]; Piperacks, Main structures [2125 h] | 85,000 | 57,800 | XN205502 | 2125 | 1445 | 934 | 55 | 200 | 200 | C | LND | X | N | XN20 | 5502 | N | 55 | X | PR | LND | 5502 | ChSK | 2125,00 |  | 27.8. | x |  |  | XNK |  | E-04-33 | UDF_G4 | t | x |  |  |  |  |  |  |  |  |  |  |  |  |  |  |
|  | H | **HVAC** |  |  |  |  |  |  |  |  |  |  |  |  |  |  |  |  |  |  |  |  |  |  |  |  |  |  |  |  |  |  |  |  |  |  |  |  |  |  |  |  |  |  |  |  |  |  |  |  |  |  |  |  |  |  |  |  |  |  |  |  |  |  |
|  | U | **Package Units** |  |  |  |  |  |  |  |  |  |  |  |  |  |  |  |  |  |  |  |  |  |  |  |  |  |  |  |  |  |  |  |  |  |  |  |  |  |  |  |  |  |  |  |  |  |  |  |  |  |  |  |  |  |  |  |  |  |  |  |  |  |  |
|  | B | **Mechanical - Stationary Equipment** |  |  |  |  |  |  |  |  |  |  |  |  |  |  |  |  |  |  |  |  |  |  |  |  |  |  |  |  |  |  |  |  |  |  |  |  |  |  |  |  |  |  |  |  |  |  |  |  |  |  |  |  |  |  |  |  |  |  |  |  |  |  |
|  | M | **Mechanical - Rotating Equipment** |  |  |  |  |  |  |  |  |  |  |  |  |  |  |  |  |  |  |  |  |  |  |  |  |  |  |  |  |  |  |  |  |  |  |  |  |  |  |  |  |  |  |  |  |  |  |  |  |  |  |  |  |  |  |  |  |  |  |  |  |  |  |
|  | R | **Piping** |  |  | 2011-10-01 | 2011-11-23 |  |  |  |  |  |  |  |  |  |  |  |  |  |  |  |  |  |  |  |  |  |  |  |  |  |  |  |  |  |  |  |  |  |  |  |  |  |  |  |  |  |  |  |  |  |  |  |  |  |  |  |  |  |  |  |  |  |  |
| XR205502 |  | CA55 SR5502 - Piping Prefabrication |  | 10d | 2011-10-01 | 2011-10-12 | P3R06AS1 (other project), ER495502 (other project) |  |  |  |  | -25d | 0d | as late as possible |  | A/G piping prefabrication [20 Fpi]; A/G Piping (Prefab) [75 h] | 92.39 |  | XR205502 | 75 | 0 | 934 | 55 | 200 | 200 | C | LND | X | R | XR20 | 5502 | R | 55 | X | PRP | LND | 5502 |  | 75,00 |  | 27.8. |  |  |  |  |  |  |  |  |  | to be dissolved | Start 19.09.11 |  |  |  |  |  |  |  |  |  |  |  |  |
| XR405502 |  | CA55 SR5502 - Piping Installation |  | 10d | 2011-10-19 | 2011-10-29 | XR405402 FF, XN205502, ER475502 (other project) FS-20d, XR205502 FS-5d, XW505502 |  |  |  |  | -25d | 0d |  |  | A/G piping field installation [50 Fpi]; A/G Piping (Field) [312.5 h] | 325.2 |  | XR405502 | 312,5 | 0 | 934 | 55 | 200 | 200 | C | LND | X | R | XR40 | 5502 | R | 55 | X | PI | LND | 5502 |  | 312,50 |  |  |  |  |  |  |  | E-06-03-12 |  |  |  | to be dissolved |  | 2011-01-20 | 2011-04-04 |  |  |  |  |  |  |  |  |  |  |
| XR605502 |  | CA55 SR5502 - Piping Pressure Tests |  | 15d | 2011-10-31 | 2011-11-17 | XR405502, X0300020 |  |  |  |  | -25d | 0d |  |  |  |  |  | XR605502 | 0 | 0 | 934 | 55 | 200 | 200 | C | LND | X | R | XR60 | 5502 | R | 55 | X | HY | LND | 5502 |  | 7 |  |  |  |  |  |  |  | E-06-03-12 |  |  |  |  |  |  |  |  |  |  |  |  |  |  |  |  |  |
| XR805502 |  | CA55 SR5502 - Piping Reinstatement |  | 10d | 2011-11-12 | 2011-11-23 | XR605502 FF+5d, IMS-C-000360 FF |  |  |  |  | 225d | 215.5d |  |  |  |  |  | XR805502 | 0 | 0 | 934 | 55 | 200 | 200 | C | LND | X | R | XR80 | 5502 | R | 55 | X | PI | LND | 5502 |  | 3 |  |  |  |  |  |  |  | E-06-03-12 |  |  |  |  |  |  |  | 2011-07-30 | 2011-10-10 |  |  |  |  |  |  |  |  |
|  | E | **Electrical** |  |  | 2010-10-16 | 2012-07-21 |  |  |  |  |  |  |  |  |  |  |  |  |  |  |  |  |  |  |  |  |  |  |  |  |  |  |  |  |  |  |  |  |  |  |  |  |  |  |  |  |  |  |  |  |  |  |  |  |  |  |  |  |  |  |  |  |  |  |
| XC915502 |  | CA55 SR5502 - Installation Earthing Foundations_CIVIL |  | 48d | 2010-10-16 A | 2011-01-18 A | XC205502 FF+5d, EE905502 (other project) | 100% |  |  |  |  |  |  | TB26 - V - Construct-Winter partly * | Grounding & Lightning [120 pcs]; Grounding & Lightning [1350 h] | 54,000 | 54,000 | XC915502 | 1350 | 1350 | 934 | 55 | 200 | 200 | C | LND | X | C | XE91 | 5502 | C | 55 | X | EA | LND | 5502 | MO11 | 1350,00 |  |  |  |  |  |  |  | E-16-07-17 |  |  |  |  |  | 2011-03-20 |  | 2011-08-30 |  |  |  |  |  |  |  |  |  |
| XE405502 |  | CA55 SR5502 - Install Cable Trays |  | 123d | 2011-06-14 A | 2011-10-15 | EE46550210 (other project), P3E16S (other project), XN205502 FF+15d |  | 10d | 2011-06-14 | 2011-11-03 | 84d | 0d |  |  | Cable trays/conduits [910 m]; Cable trays [2730 h] | 109,200 | 48,000 | XE405502 | 2730 | 1200 | 934 | 55 | 200 | 200 | C | LND | X | E | XE40 | 5502 | E | 55 | X | EL | LND | 5502 | URMA | 2730,00 |  |  |  |  | x |  |  | E-15-01-05 | UDF_G4 | m |  |  |  | 2011-03-25 |  | 2011-06-30 |  | 1300 | 2011-04-16 | 2011-06-16 | Plot plan | 2011-09-20 | 2011-05-23 | UDF_G2 |  |
| XE915502 |  | CA55 SR5502 - Installation Earthing Foundations_E/I |  | 5d | 2011-10-17 | 2011-10-21 | XN205502, XE405502, XJ425502 |  |  |  |  | 158d | 180.5d |  | TB26 - V - Construct-Winter partly * |  |  |  | XE915502 | 0 | 0 | 934 | 55 | 200 | 200 | C | LND | X | E | XE91 | 5502 | E | 55 | X | EA | LND | 5502 | URMA | 135 |  |  |  |  |  |  |  | E-16-07-17 |  |  |  |  |  | 2011-03-20 |  | 2011-08-30 |  |  |  |  |  | 2012-04-10 | 2011-05-23 | UDF_G2 |  |
| XE705502 |  | CA55 SR5502 - Install Lighting & Small Power |  | 30d | 2011-11-08 | 2011-12-12 | XP341610 FS+50d, XE405502, P3E03S2 (other project), EE765502 (other project) |  |  |  |  | 162d | 184.5d |  |  | Cable Pulling [800 m]; Lighting illuminates [100 pcs]; Cable pulling [400 h]; Lighting (iluminates) [1000 h] | 56,000 |  | XE705502 | 1400 | 0 | 934 | 55 | 200 | 200 | C | LND | X | E | XE70 | 5502 | E | 55 | X | EL | LND | 5502 | URMA | 1400,00 |  |  |  |  |  |  |  | E-16-03-01 |  |  |  |  |  | 2011-05-10 |  | 2012-01-31 |  |  |  |  |  | 2012-05-10 | 2011-08-15 | UDF_G2 |  |
| XE805502 |  | CA55 SR5502 - Install Heat Tracing |  | 30d | 2012-03-23 | 2012-04-26 | E3E1950 (other project), P3E19S (other project), XR405502, XR605502, XR605501 |  |  |  |  | 50d | 0d |  |  | Electrical Heat Tracing [2200 m]; Electrical heat tracing [1100 h] | 44,000 |  | XE805502 | 1100 | 0 | 934 | 55 | 200 | 200 | C | LND | X | E | XE80 | 5502 | E | 55 | X | HT | LND | 5502 | URMA | 1100,00 |  | 27.8. |  |  |  |  |  | E-16-04-01 |  |  |  |  |  | 2011-06-20 |  | 2012-03-20 |  |  |  |  |  | 2012-06-30 | 2011-09-15 | UDF_G2 | 005 |
| XE505502 |  | CA55 SR5502 - Cable Pulling Electric |  | 40d | 2012-06-04 | 2012-07-21 | XE505501 SS+5d, XE500C01, EE565502 (other project), XE405502 |  |  |  |  | -87.5d | 0d |  | TB26 - V - Construct-Winter partly * | Cable Pulling [14000 m]; Cable pulling [7000 h] | 280,000 |  | XE505502 | 7000 | 0 | 934 | 55 | 200 | 200 | C | LND | X | E | XE50 | 5502 | E | 55 | X | EL | LND | 5502 | URMA | 7000,00 |  |  |  |  |  |  |  | E-16-01-01 |  | m |  |  |  | 2011-05-20 |  | 2012-02-10 |  | 14500 | 2011-07-26 | 2011-09-09 | Plot plan | 2012-07-01 | 2011-10-01 | UDF_G2 |  |

Notes:
- XC115502: P3 Activity Log Info: incl. Dewatering/Drainage
- XC155502: P3 Activity Log Info: 137 driven piles expected,20/d/machine
- XC205502: Current Status: 12.01.2011 (Oxana): Ressourcen wurden nicht geдndert / angepasst, die ausgewiesenen bereits eine geringe
- XC305502: P3 Activity Log Info: Clarification Prefabrication Catch Basins / Current Status: 12.0.2011 (O. Siegel): nach Rьcksprache mit MO11 am 11 und / 12.Januar 11, wurde der 25-April-11 als Starttermin besprochen.
- XN715502: Scope: 09.02.2011: weight: 50 ton
- XN205502: P3 Activity Log Info: Clarification Preassembly / Current Status: die Ьbergabe erfolgte am 04-Feb-11. Da die notwendigen / Materialien fehelen (Probleme mit Lieferung von Groteilen
- XE405502: UDF_PREDECESSOR: XN30, Piping 50%
- XE915502: UDF_PREDECESSOR: XN30, DEL XE40, DEL XE80, DEL XJ40, Civil 100%, Equipment 100%
- XE705502: UDF_PREDECESSOR: XE40, Civil 100%, HVAC ducts, Finishing works partly
- XE805502: UDF_PREDECESSOR: XR40, Piping 50% pressure tests
- XE505502: UDF_PREDECESSOR: XE40, XE50, DEL XE34

| ID | WBS | Activity | Type | Duration | Start | Finish | Predecessors | Complete | Remaining | Planned start | Planned finish | Total float | Free float | Constraint | Calendar | Resources | Cost | Actual cost | TB26 Ressource Budget | UDF_CONTRACT START DATE | UDF_CONTRACT FINISH DATE | UDF_CONTRACT ITEM | TB26 Semantics | TB26 Material Res Values | UDF_ELECTRICAL START | UDF_ELECTRICAL FINISH | UDF_ELECTRICAL SEQUENCE | UDF_CONTRACT FINISH DATE REV1 | UDF_CONTRACT START DATE REV1 | UDF_SAVE ACT ID | UDF_CHECK BASELINE | UDF_BUDGETED LABOR UNIT | UDF_ACTUAL LABOR UNIT | UDF_PREDECESSOR | UDF_INDICATOR | Department | Constr. Area | PMT-Area | PMT-Schedule Org | PMT-Phase | PMT-Respons. | WBS Phase | WBS Discipline | WBS Type of Work | WBS Objects | Russia WBS Discipline (Russia) | Russia Construction Area | Russia WBS Phase | IMS | UPT | Russia WBS Objects | Subcontractor | UDF_SELECT UPDATE PROGRESS | Inquiry/Order No | UDF_CHECK RESOURCE DATES | UDF_Concrete | Type of Work | Zeigen/n. Zeigen | 4 week lookahead | UDF_CONTRACT INDICATOR | UDF_CHECK CRITICAL PATH | UDF_SELECT | Comments | UDF_COMMENTS_0827 | UDF_PLANNED START | UDF_PLANNED FINISH |
| --- | --- | --- | --- | --- | --- | --- | --- | --- | --- | --- | --- | --- | --- | --- | --- | --- | --- | --- | --- | --- | --- | --- | --- | --- | --- | --- | --- | --- | --- | --- | --- | --- | --- | --- | --- | --- | --- | --- | --- | --- | --- | --- | --- | --- | --- | --- | --- | --- | --- | --- | --- | --- | --- | --- | --- | --- | --- | --- | --- | --- | --- | --- | --- | --- | --- | --- |
|  | J | **Instrumentation** |  |  | 2011-10-05 | 2012-08-02 |  |  |  |  |  |  |  |  |  |  |  |  |  |  |  |  |  |  |  |  |  |  |  |  |  |  |  |  |  |  |  |  |  |  |  |  |  |  |  |  |  |  |  |  |  |  |  |  |  |  |  |  |  |  |  |  |  |  |  |  |
| XJ425502 |  | CA55 SR5502 - Install CableTrays Instrumentation |  | 10d | 2011-10-05 | 2011-10-15 | EJ46550210 (other project), XE405502 FF |  |  |  |  | 58d | 0d |  | TB26 - V - Construct-Winter partly * | Main cable trays [260 m]; Install Main Cable trays [780 h] | 31,200 |  | 780,00 | 2011-03-25 | 2011-06-30 | E-15-01-05 | m | 850 | 2011-04-16 | 2011-06-16 | Plot plan | 2011-09-20 | 2011-05-23 | XJ425502 | x | 780 | 0 | XE40, XJ32, Equipment 100%, Piping 50% | UDF_G2 | 934 | 55 | 200 | 200 | C | LND | X | J | XJ42 | 5502 | J | 55 | X | IN | LND | 5502 | URMA |  |  |  |  |  |  |  |  |  |  |  |  |  |  |
| XJ525502 |  | CA55 SR5502 - Pulling Instrument Cables |  | 50d | 2012-06-04 | 2012-08-02 | XJ525501 SS+5d, XE500C01, XJ525402 SS+15d, XJ425502 |  |  |  |  | -82.5d | 0d |  | TB26 - V - Construct-Winter partly * | Multicore cables [3400 m]; Pull multicore cables [1700 h] | 68,000 |  | 1700,00 | 2011-03-20 | 2011-09-20 | E-17-04-17 | m | 2500 | 2011-08-02 | 2011-09-28 |  | 2012-03-30 | 2011-08-10 | XJ525502 |  | 1700 | 0 | XE40, XJ32, XJ52 | UDF_G2 | 934 | 55 | 200 | 200 | C | LND | X | J | XJ52 | 5502 | J | 55 | X | IN | LND | 5502 | URMA |  |  |  |  |  |  |  |  |  |  |  |  |  |  |
|  | S | **Safety & Environment** |  |  |  |  |  |  |  |  |  |  |  |  |  |  |  |  |  |  |  |  |  |  |  |  |  |  |  |  |  |  |  |  |  |  |  |  |  |  |  |  |  |  |  |  |  |  |  |  |  |  |  |  |  |  |  |  |  |  |  |  |  |  |  |  |
|  | W | **Painting** |  |  | 2011-10-07 | 2011-10-18 |  |  |  |  |  |  |  |  |  |  |  |  |  |  |  |  |  |  |  |  |  |  |  |  |  |  |  |  |  |  |  |  |  |  |  |  |  |  |  |  |  |  |  |  |  |  |  |  |  |  |  |  |  |  |  |  |  |  |  |  |
| XW505502 |  | CA55 SR5502 - Surf.Protection Piping |  | 10d | 2011-10-07 | 2011-10-18 | XR205502 FF+5d |  |  |  |  | -25d | 0d | as late as possible |  | Piping painting [10 sqm]; Piping painting [25 h] | 753.87 |  | 25,00 |  |  |  |  |  |  |  |  |  |  | XW505502 |  | 25 | 0 |  |  | 934 | 55 | 200 | 200 | C | LND | X | W | XW50 | 5502 | W | 55 | X | PA | LND | 5502 |  | 27.8. |  |  |  |  |  |  |  |  |  |  |  |  |  |
|  | V | **Insulation** |  |  | 2012-04-16 | 2012-06-27 |  |  |  |  |  |  |  |  |  |  |  |  |  |  |  |  |  |  |  |  |  |  |  |  |  |  |  |  |  |  |  |  |  |  |  |  |  |  |  |  |  |  |  |  |  |  |  |  |  |  |  |  |  |  |  |  |  |  |  |  |
| XV505502 |  | CA55 SR5502 - Insulation Piping |  | 60d | 2012-04-16 | 2012-06-27 | XE805502 SS+20d, XE805502 FF+20d, XV500C00 SS+0.4d |  |  |  |  | 50d | 40.5d |  | TB26 - T - Construct-Winter-3 (Dec/Jan/Feb free) * | Piping insulation [100 sqm]; Piping insulation [750 h] | 2,861.75 |  | 750,00 |  | 2012-04-30 | E-13-01 |  |  |  |  |  |  |  | XV505502 |  | 750 | 0 |  |  | 934 | 55 | 200 | 200 | C | LND | X | V | XV50 | 5502 | V | 55 | X | INS | LND | 5502 |  | 27.8. |  |  |  |  |  |  |  |  |  |  |  |  |  |
|  | 03 | **CA5503** |  |  | 2008-09-24 | 2012-08-14 |  |  |  |  |  |  |  |  |  |  |  |  |  |  |  |  |  |  |  |  |  |  |  |  |  |  |  |  |  |  |  |  |  |  |  |  |  |  |  |  |  |  |  |  |  |  |  |  |  |  |  |  |  |  |  |  |  |  |  |  |
|  | C | **Civil Work** |  |  | 2008-09-24 | 2012-03-21 |  |  |  |  |  |  |  |  |  |  |  |  |  |  |  |  |  |  |  |  |  |  |  |  |  |  |  |  |  |  |  |  |  |  |  |  |  |  |  |  |  |  |  |  |  |  |  |  |  |  |  |  |  |  |  |  |  |  |  |  |
| XC115503 |  | CA55 SR5503 - Excavation&Surface Prep by U/I/O |  | 294d | 2008-09-24 A | 2009-09-30 A | XC115502 SS | 100% |  |  |  |  |  |  |  |  |  |  |  |  |  |  |  |  |  |  |  |  |  | XC115503 |  | 0 | 0 |  |  | 934 | 55 | 200 | 200 | C | UIO | X | C | XC11 | 5503 | C | 55 | X | CW | LND | 5503 | MO11 |  |  |  |  |  |  |  |  |  |  |  |  |  |  |
| XC11550305 |  | CA55 SR5503 - Excavation |  | 11d | 2010-05-20 A | 2010-06-01 A | XC11550205 SS+2d | 100% |  |  |  |  |  |  |  | Excavation [7000 cbm]; Excavation [3500 h] | 280,000 | 280,000 | 3500,00 |  |  |  |  |  |  |  |  |  |  | XC11550305 |  | 3500 | 3500 |  |  | 934 | 55 | 200 | 200 | C | MO02 | X | C | XC11 | 5503 | C | 10 | X | P | LND | 1010 | MO11 |  | 999 |  |  |  |  |  |  |  |  |  |  |  |  |
| XC11550310 |  | CA55 SR5503 - SubBase (Gravel/Geogrid) for Concrete |  | 7d | 2010-05-31 A | 2010-06-08 A | XC11550305 | 100% |  | 2010-05-31 | 2010-06-07 |  |  |  |  | Sub Base for Concrete/Paving&Roads (Gravel) [600 cbm]; Subbase for Concrete [600 h] | 60,000 | 20,000 | 600,00 |  |  |  |  |  |  |  |  |  |  | XC11550310 |  | 600 | 600 |  |  | 934 | 55 | 200 | 200 | C | MO02 | X | C | XC11 | 5503 | C | 10 | X | P | LND | 1010 | MO11 |  | 999 |  |  |  |  |  |  |  |  |  |  |  |  |
| XC155503 |  | CA55 SR5503 - Piling |  | 34d | 2010-06-08 A | 2010-07-16 A | IMS-C-000010 FF, XC11550305, XC11550310, F2910, XC115503, EC155503 (other project) FS+8d | 100% |  |  |  |  |  |  |  | Piles driven [147 pcs]; Piles driven [1102.5 h] | 44,100 | 44,100 | 1102,50 |  |  |  |  |  |  |  |  |  |  | XC155503 |  | 1102,5 | 1102,5 |  |  | 934 | 55 | 200 | 200 | C | MO02 | X | C | XC15 | 5503 | C | 55 | X | P | LND | 5503 | MO11 |  |  |  |  |  |  |  |  |  |  |  |  |  |  |
| XC205503 |  | CA55 SR5503 - Concrete Works |  | 45d | 2010-09-20 A | 2010-11-16 A | EC285503 (other project) FS+20d, XC155503, EC45550305 (other project) | 100% |  |  |  |  |  |  | TB26 - V - Construct-Winter partly * | Concrete works [300 cbm]; Concrete works [9000 h] | 360,000 | 360,000 | 9000,00 |  |  |  |  |  |  |  |  |  |  | XC205503 |  | 9000 | 9000 |  |  | 934 | 55 | 200 | 200 | C | CiC | X | C | XC20 | 5503 | C | 55 | X | mis | LND | 5503 | MO11 |  |  |  |  |  |  |  |  |  |  |  |  |  |  |
| XC195503 |  | CA55 SR5503 - Backfill |  | 23d | 2011-08-08 A | 2011-09-02 | XC915503 FF, IMS-C-000040 FF |  | 6d |  |  | 191d | 62d | start on or after 2011-08-08 | TB26 - T - Construct-Winter-3 (Dec/Jan/Feb free) * | Backfill & Compaction [2500 cbm]; Backfill & Compaction [3750 h] | 225,000 | 127,500 | 3750,00 |  |  |  |  |  |  |  |  |  |  | XC195503 |  | 3750 | 0 |  |  | 934 | 55 | 200 | 200 | C | CiC | X | C | XC19 | 5503 | C | 55 | X | mis | LND | 5503 | MO11 | 27.8. |  | x |  |  |  |  |  |  |  |  |  |  |  |
| XC305503 |  | CA55 SR5503 - UG Installation (incl. Precast Manholes) |  | 35d | 2011-10-17 | 2011-12-12 | P3R02AS1 (other project), ER445503 (other project), XC205503 SS+12d, XC300C00, EC305503 (other project) FS+20d, XC310C00, P3R02S1 (other project), P3R02BS (other project) |  |  |  |  | -13d | 0d | start on or after 2011-10-17 | TB26 - V - Construct-Winter partly * |  |  |  |  |  |  |  |  |  |  |  |  |  |  | XC305503 |  | 0 | 0 |  |  | 934 | 55 | 200 | 200 | C | CiC | X | C | XC30 | 5503 | C | 55 | X | mis | LND | 5503 |  | 27.8. |  |  | 1 |  |  |  |  |  |  |  |  |  |  |
| XC605503 |  | CA55 SR5503 - Paving |  | 20d | 2011-11-22 | 2012-03-21 | XC605502 SS+3d, XN205503 SS+20d, XC195503 |  |  |  |  | 129d | 119.5d |  | TB26 - T - Construct-Winter-3 (Dec/Jan/Feb free) * | Gravel [380 sqm]; Gravel [19 h] | 824.08 |  | 19,00 |  |  |  |  |  |  |  |  |  |  | XC605503 |  | 19 | 0 |  |  | 934 | 55 | 200 | 200 | C | CiC | X | C | XC60 | 5503 | C | 55 | X | PV | LND | 5503 | MO11 |  |  |  | 1 |  |  |  |  |  |  |  |  |  |  |
|  | N | **Structural Steel** |  |  | 2011-02-01 | 2011-09-17 |  |  |  |  |  |  |  |  |  |  |  |  |  |  |  |  |  |  |  |  |  |  |  |  |  |  |  |  |  |  |  |  |  |  |  |  |  |  |  |  |  |  |  |  |  |  |  |  |  |  |  |  |  |  |  |  |  |  |  |  |
| XN705503 |  | CA55 SR5503 - KMD Assy Drawings | milestone | 0d | 2011-02-01 A | 2011-02-01 A |  | 100% |  |  |  |  |  | finish on 2011-01-31 |  |  |  |  | 22t |  |  |  |  |  |  |  |  |  |  | XN705503 | x | 0 | 0 |  |  | 934 | 55 | 200 | 200 | C | LND | X | N | XN05 | 5503 | N | 55 | X | PR | LND | 5503 |  |  |  |  |  | XNK | KMD |  |  |  |  |  |  |  |  |
| XN715503 |  | CA55 SR5503 - Steel Deliveries | milestone | 0d | 2011-02-04 A | 2011-02-04 A |  | 100% |  |  |  |  |  | finish on 2011-02-04 | TB26 - 3 - Construction Normal 7days * CA17 |  |  |  | 22t |  |  |  |  |  |  |  |  |  |  | XN715503 |  | 0 | 0 |  |  | 934 | 55 | 200 | 200 | C | LND | X | N | XN06 | 5503 | N | 55 | X | PR | LND | 5503 |  |  |  |  |  | XNK | SD |  |  |  |  |  |  |  |  |
| XN205503 |  | CA55 SR5503 - Installation Steel Structure |  | 89d | 2011-02-07 A | 2011-06-10 A | XN705503, EN685503 (other project), XN205502 SS-10d, P3N012D (other project) FS+10d, P3N01MN (other project), XN715503 FS+10d, XC205503 SS+20d, XC915503 | 100% |  | 2011-02-07 | 2011-06-09 |  |  |  | TB26 - V - Construct-Winter partly * | Piperacks, Main Structures [70 t]; Piperacks, Main structures [2975 h] | 119,000 | 119,000 | 2975,00 |  |  | E-04-34 | t |  |  |  |  |  |  | XN205503 |  | 2975 | 2975 |  |  | 934 | 55 | 200 | 200 | C | LND | X | N | XN20 | 5503 | N | 55 | X | PR | LND | 5503 | ChSK |  |  |  |  | XNK |  | x |  |  |  |  |  |  |  |
| XN405503 |  | CA55 SR5503 - Install Railings,Ladders,etc. |  | 79d | 2011-06-18 A | 2011-09-17 | XE405503, XN205503 |  | 19d |  |  | 234d | 256.5d |  |  | Ladders & platforms [3 t]; Ladders & platforms [300 h] | 362.15 |  | 300,00 |  |  |  |  |  |  |  |  |  |  | XN405503 | x | 300 | 100 |  |  | 934 | 55 | 200 | 200 | C | LND | X | N | XN40 | 5503 | N | 55 | X | SS | LND | 5503 | ChSK | 27.8. |  | actual finish |  | XNK |  |  | UDF_G4 | Check Roof - Cladding |  |  |  |  |  |
|  | H | **HVAC** |  |  |  |  |  |  |  |  |  |  |  |  |  |  |  |  |  |  |  |  |  |  |  |  |  |  |  |  |  |  |  |  |  |  |  |  |  |  |  |  |  |  |  |  |  |  |  |  |  |  |  |  |  |  |  |  |  |  |  |  |  |  |  |  |
|  | U | **Package Units** |  |  |  |  |  |  |  |  |  |  |  |  |  |  |  |  |  |  |  |  |  |  |  |  |  |  |  |  |  |  |  |  |  |  |  |  |  |  |  |  |  |  |  |  |  |  |  |  |  |  |  |  |  |  |  |  |  |  |  |  |  |  |  |  |
|  | B | **Mechanical - Stationary Equipment** |  |  |  |  |  |  |  |  |  |  |  |  |  |  |  |  |  |  |  |  |  |  |  |  |  |  |  |  |  |  |  |  |  |  |  |  |  |  |  |  |  |  |  |  |  |  |  |  |  |  |  |  |  |  |  |  |  |  |  |  |  |  |  |  |
|  | M | **Mechanical - Rotating Equipment** |  |  |  |  |  |  |  |  |  |  |  |  |  |  |  |  |  |  |  |  |  |  |  |  |  |  |  |  |  |  |  |  |  |  |  |  |  |  |  |  |  |  |  |  |  |  |  |  |  |  |  |  |  |  |  |  |  |  |  |  |  |  |  |  |
|  | R | **Piping** |  |  | 2011-12-02 | 2012-04-05 |  |  |  |  |  |  |  |  |  |  |  |  |  |  |  |  |  |  |  |  |  |  |  |  |  |  |  |  |  |  |  |  |  |  |  |  |  |  |  |  |  |  |  |  |  |  |  |  |  |  |  |  |  |  |  |  |  |  |  |  |
| XR205503 |  | CA55 SR5503 - Piping Prefabrication |  | 10d | 2011-12-02 | 2011-12-13 | P3R06AS (other project) FF+10d, P3R06AS1 (other project), ER495503 (other project) |  |  |  |  | -97d | 0d | as late as possible |  | A/G piping prefabrication [60 Fpi]; A/G Piping (Prefab) [225 h] | 92.39 |  | 225,00 |  |  |  |  |  |  |  |  |  |  | XR205503 |  | 225 | 0 |  |  | 934 | 55 | 200 | 200 | C | LND | X | R | XR20 | 5503 | R | 55 | X | PRP | LND | 5503 |  |  |  |  |  |  |  |  |  |  | OMUS-1 | to be dissolved | Start 19.09.11 |  |  |
| XR405503 |  | CA55 SR5503 - Piping Installation |  | 10d | 2011-12-26 | 2012-01-23 | XR205503 SS+20d, XR405601 SS, XE405503 SS+20d, XN205503, ER475503 (other project) FS-20d, XW505503 |  |  |  |  | -78d | 2d |  | TB26 - V - Construct-Winter partly * | A/G piping field installation [50 Fpi]; A/G Piping (Field) [312.5 h] | 325.2 |  | 312,50 | 2011-01-20 |  | E-06-03-12 |  |  |  |  |  |  |  | XR405503 |  | 312,5 | 0 |  |  | 934 | 55 | 200 | 200 | C | LND | X | R | XR40 | 5503 | R | 55 | X | PI | LND | 5503 |  |  |  |  |  |  |  |  |  |  | OMUS-1 | to be dissolved |  | 2011-04-23 |  |
| XR605503 |  | CA55 SR5503 - Piping Pressure Tests |  | 15d | 2012-03-01 | 2012-03-22 | XR405503 FS+15d, X0300020 |  |  |  |  | -44d | 0d |  | TB26 - T - Construct-Winter-3 (Dec/Jan/Feb free) * |  |  |  | 7 |  |  | E-06-03-12 |  |  |  |  |  |  |  | XR605503 |  | 0 | 0 |  |  | 934 | 55 | 200 | 200 | C | LND | X | R | XR60 | 5503 | R | 55 | X | HY | LND | 5503 |  |  |  |  |  |  |  |  |  |  | OMUS-1 |  |  |  |  |
| XR805503 |  | CA55 SR5503 - Piping Reinstatement |  | 20d | 2012-03-09 | 2012-04-05 | XR605503 FF+10d, IMS-C-000360 FF |  |  |  |  | 303.5d |  |  | TB26 - V - Construct-Winter partly * |  |  |  | 3 |  | 2011-07-30 | E-06-03-12 |  |  |  |  |  |  |  | XR805503 |  | 0 | 0 |  |  | 934 | 55 | 200 | 200 | C | LND | X | R | XR80 | 5503 | R | 55 | X | PI | LND | 5503 |  |  |  |  |  |  |  |  |  |  | OMUS-1 |  |  |  | 2011-09-29 |

Notes:
- XW505502: P3 Activity Log Info: Clarification Surface Protection during Prefab
- XC115503: P3 Activity Log Info: incl. Dewatering/Drainage
- XC155503: P3 Activity Log Info: 112 driven piles expected,20/d/machine
- XC305503: P3 Activity Log Info: Clarification Prefabrication Catch Basins / Current Status: 12.0.2011 (O. Siegel): nach Rьcksprache mit MO11 am 11 und / 12.Januar 11, wurde der 25-April-11 als Starttermin besprochen.
- XN715503: Scope: 09.02.2011: weight: 100 ton
- XN205503: P3 Activity Log Info: Clarification Preassembly
- XR205503: Current Status: 10.03.2011 (O.Siegel): Material nocht nicht ausreichend / vorhanden auf der Baustelle. Nach Absprache mit M. Siegel wurde Startdatum / fьr Piping Prefabrication auf Anfang April 2011 gesetzt.
- XR405503: Current Status: 10.03.2011 (O.Siegel): Material nocht nicht ausreichend / vorhanden auf der Baustelle. Nach Absprache mit M. Siegel wurde Startdatum / fьr Piping Prefabrication auf Anfang April 2011 gesetzt.

| ID | WBS | Activity | Type | Duration | Start | Finish | Predecessors | Complete | Remaining | Planned start | Planned finish | Total float | Free float | Constraint | Calendar | Resources | Cost | Actual cost | TB26 Ressource Budget | UDF_CONTRACT START DATE | UDF_CONTRACT FINISH DATE | UDF_CONTRACT ITEM | UDF_SAVE ACT ID | UDF_BUDGETED LABOR UNIT | UDF_ACTUAL LABOR UNIT | Department | Constr. Area | PMT-Area | PMT-Schedule Org | PMT-Phase | PMT-Respons. | WBS Phase | WBS Discipline | WBS Type of Work | WBS Objects | Russia WBS Discipline (Russia) | Russia Construction Area | Russia WBS Phase | IMS | UPT | Russia WBS Objects | Subcontractor | UDF_CONTRACT FINISH DATE REV1 | UDF_CONTRACT START DATE REV1 | UDF_INDICATOR | UDF_CONTRACT INDICATOR | TB26 Semantics | TB26 Material Res Values | UDF_ELECTRICAL START | UDF_ELECTRICAL FINISH | UDF_ELECTRICAL SEQUENCE | UDF_SELECT UPDATE PROGRESS | UDF_CHECK BASELINE | UDF_CHECK RESOURCE DATES | Comments | UDF_Vendor Representatives | UDF_SELECT | Type of Work | Inquiry/Order No | UDF_Concrete |
| --- | --- | --- | --- | --- | --- | --- | --- | --- | --- | --- | --- | --- | --- | --- | --- | --- | --- | --- | --- | --- | --- | --- | --- | --- | --- | --- | --- | --- | --- | --- | --- | --- | --- | --- | --- | --- | --- | --- | --- | --- | --- | --- | --- | --- | --- | --- | --- | --- | --- | --- | --- | --- | --- | --- | --- | --- | --- | --- | --- | --- |
|  | E | **Electrical** |  |  | 2010-09-20 | 2012-07-10 |  |  |  |  |  |  |  |  |  |  |  |  |  |  |  |  |  |  |  |  |  |  |  |  |  |  |  |  |  |  |  |  |  |  |  |  |  |  |  |  |  |  |  |  |  |  |  |  |  |  |  |  |  |  |
| XC915503 |  | CA55 SR5503 - Installation Earthing Foundations_CIVIL |  | 66d | 2010-09-20 A | 2010-12-29 A | XC205503 FF+5d, IMS-C-000230 FF, EE905503 (other project) | 100% |  |  |  |  |  |  | TB26 - V - Construct-Winter partly * | Grounding & Lightning [120 pcs]; Grounding & Lightning [1350 h] | 54,000 | 54,000 | 1350,00 | 2011-03-20 | 2011-08-30 | E-16-07-17 | XC915503 | 1350 | 1350 | 934 | 55 | 200 | 200 | C | LND | X | C | XE91 | 5503 | C | 55 | X | EA | LND | 5503 | MO11 |  |  |  |  |  |  |  |  |  |  |  |  |  |  |  |  |  |  |
| XE915503 |  | CA55 SR5503 - Installation Earthing Foundations_E/I |  | 41d | 2011-04-23 A | 2011-06-11 A | XN205503 | 100% |  |  |  |  |  |  | TB26 - V - Construct-Winter partly * |  |  |  | 135 | 2011-03-20 | 2011-08-30 | E-16-07-17 | XE915503 | 0 | 0 | 934 | 55 | 200 | 200 | C | LND | X | E | XE91 | 5503 | E | 55 | X | EA | LND | 5503 | URMA | 2012-04-10 | 2011-05-23 | UDF_G2 |  |  |  |  |  |  |  |  |  |  |  |  |  |  |  |
| XE405503 |  | CA55 SR5503 - Install Cable Trays |  | 95d | 2011-05-23 A | 2011-09-10 | EE46550310 (other project), XN205503 SS+20d, P3E16S (other project) | 100% | 13d |  |  | 5d | 170.5d | start on or after 2011-05-23 | TB26 - V - Construct-Winter partly * | Cable trays/conduits [880 m]; Cable trays [2640 h] | 105,600 | 54,840 | 2640,00 | 2011-03-25 | 2011-06-30 | E-15-01-05 | XE405503 | 2640 | 1188 | 934 | 55 | 200 | 200 | C | LND | X | E | XE40 | 5503 | E | 55 | X | EL | LND | 5503 | URMA | 2011-09-20 | 2011-05-23 | UDF_G2 | UDF_G4 | m | 1300 | 2011-04-27 | 2011-06-27 | Plot plan | 27.8. | x | actual finish |  |  |  |  |  |  |
| XC705503 |  | CA55 SR5503 - Install Lighting & Small Power |  | 20d | 2011-08-25 A | 2011-09-16 | XE405503, EE765503 (other project), XP341610 FS+50d |  | 18d |  |  | 188d | 210.5d |  | TB26 - V - Construct-Winter partly * | Cable Pulling [800 m]; Lighting illuminates [100 pcs]; Cable pulling [400 h]; Lighting (iluminates) [1000 h] | 56,000 | 5,600 | 1400,00 | 2011-05-10 | 2012-01-31 | E-16-03-01 | XC705503 | 1400 | 0 | 934 | 55 | 200 | 200 | C | LND | X | E | XE70 | 5503 | E | 55 | X | EL | LND | 5503 | URMA | 2012-05-10 | 2011-08-15 | UDF_G2 |  |  |  |  |  |  | 27.8. |  | ok | boarding needed |  |  |  |  |  |
| XE805503 |  | CA55 SR5503 - Install Heat Tracing |  | 30d | 2012-03-28 | 2012-05-03 | XW505503 FF+5d, E3E1950 (other project), P3E19S (other project), XR605503 SS+18d |  |  |  |  | 45d | 0d |  | TB26 - V - Construct-Winter partly * | Electrical Heat Tracing [2200 m]; Electrical heat tracing [1100 h] | 44,000 |  | 1100,00 | 2011-06-20 | 2012-03-20 | E-16-04-01 | XE805503 | 1100 | 0 | 934 | 55 | 200 | 200 | C | LND | X | E | XE80 | 5503 | E | 55 | X | HT | LND | 5503 | URMA | 2012-06-30 | 2011-09-15 | UDF_G2 |  |  |  |  |  |  |  |  |  |  | 005 |  |  |  |  |
| XE505503 |  | CA55 SR5503 - Cable Pulling Electric |  | 30d | 2012-06-04 | 2012-07-10 | XE500C01, XE505502 SS, XE405503, EE565503 (other project) |  |  |  |  | 9.5d | 0d |  | TB26 - V - Construct-Winter partly * | Cable Pulling [14000 m]; Cable pulling [7000 h] | 280,000 |  | 7000,00 | 2011-05-20 | 2012-02-10 | E-16-01-01 | XE505503 | 7000 | 0 | 934 | 55 | 200 | 200 | C | LND | X | E | XE50 | 5503 | E | 55 | X | EL | LND | 5503 | URMA | 2012-07-01 | 2011-10-01 | UDF_G2 |  | m | 14500 | 2011-08-02 | 2011-09-05 | Plot plan |  |  |  |  |  |  |  |  |  |
|  | J | **Instrumentation** |  |  | 2011-07-04 | 2012-08-14 |  |  |  |  |  |  |  |  |  |  |  |  |  |  |  |  |  |  |  |  |  |  |  |  |  |  |  |  |  |  |  |  |  |  |  |  |  |  |  |  |  |  |  |  |  |  |  |  |  |  |  |  |  |  |
| XJ425503 |  | CA55 SR5503 - Install CableTrays Instrumentation |  | 47d | 2011-07-04 A | 2011-08-26 A | EJ46550310 (other project), XE405503 | 100% |  |  |  |  |  |  | TB26 - V - Construct-Winter partly * | Main cable trays [270 m]; Install Main Cable trays [810 h] | 32,400 |  | 810,00 | 2011-03-25 | 2011-06-30 | E-15-01-05 | XJ425503 | 810 | 0 | 934 | 55 | 200 | 200 | C | LND | X | J | XJ42 | 5503 | J | 55 | X | IN | LND | 5503 | URMA | 2011-09-20 | 2011-05-23 | UDF_G2 |  | m | 850 | 2011-04-27 | 2011-06-27 | Plot plan |  | x |  | boarding needed |  |  |  |  |  |
| XJ525503 |  | CA55 SR5503 - Pulling Instrument Cables |  | 30d | 2012-07-10 | 2012-08-14 | XJ525502 SS, XJ425503, XE500C01, XE505503 |  |  |  |  | 9.5d | 0d |  | TB26 - V - Construct-Winter partly * | Multicore cables [2700 m]; Pull multicore cables [1350 h] | 54,000 |  | 1350,00 | 2011-03-20 | 2011-09-20 | E-17-04-17 | XJ525503 | 1350 | 0 | 934 | 55 | 200 | 200 | C | LND | X | J | XJ52 | 5503 | J | 55 | X | IN | LND | 5503 | URMA | 2012-03-30 | 2011-08-10 | UDF_G2 |  | m | 1950 | 2011-09-29 | 2011-11-02 |  |  |  |  |  |  |  |  |  |  |
|  | S | **Safety & Environment** |  |  |  |  |  |  |  |  |  |  |  |  |  |  |  |  |  |  |  |  |  |  |  |  |  |  |  |  |  |  |  |  |  |  |  |  |  |  |  |  |  |  |  |  |  |  |  |  |  |  |  |  |  |  |  |  |  |  |
|  | W | **Painting** |  |  | 2011-12-14 | 2011-12-24 |  |  |  |  |  |  |  |  |  |  |  |  |  |  |  |  |  |  |  |  |  |  |  |  |  |  |  |  |  |  |  |  |  |  |  |  |  |  |  |  |  |  |  |  |  |  |  |  |  |  |  |  |  |  |
| XW505503 |  | CA55 SR5503 - Surf.Protection Piping |  | 10d | 2011-12-14 | 2011-12-24 | XR205503 FF+5d |  |  |  |  | -97d | 0d | as late as possible |  | Piping painting [10 sqm]; Piping painting [25 h] | 753.87 |  | 25,00 |  |  |  | XW505503 | 25 | 0 | 934 | 55 | 200 | 200 | C | LND | X | W | XW50 | 5503 | W | 55 | X | PA | LND | 5503 |  |  |  |  |  |  |  |  |  |  |  |  |  |  |  | OMUS-1 |  |  |  |
|  | V | **Insulation** |  |  | 2012-04-21 | 2012-07-03 |  |  |  |  |  |  |  |  |  |  |  |  |  |  |  |  |  |  |  |  |  |  |  |  |  |  |  |  |  |  |  |  |  |  |  |  |  |  |  |  |  |  |  |  |  |  |  |  |  |  |  |  |  |  |
| XV505503 |  | CA55 SR5503 - Insulation Piping |  | 60d | 2012-04-21 | 2012-07-03 | XE805503 SS+20d |  |  |  |  | 45d | 35.5d |  | TB26 - T - Construct-Winter-3 (Dec/Jan/Feb free) * | Piping insulation [180 sqm]; Piping insulation [1350 h] | 2,861.75 |  | 1350,00 |  | 2012-04-30 | E-13-01 | XV505503 | 1350 | 0 | 934 | 55 | 200 | 200 | C | LND | X | V | XV50 | 5503 | V | 55 | X | INS | LND | 5503 |  |  |  |  |  |  |  |  |  |  |  |  |  |  |  | OMUS-1 |  |  |  |
|  | 56 | **CA56 - Pipe Rack** |  |  | 2008-09-24 | 2012-08-02 |  |  |  |  |  |  |  |  |  |  |  |  |  |  |  |  |  |  |  |  |  |  |  |  |  |  |  |  |  |  |  |  |  |  |  |  |  |  |  |  |  |  |  |  |  |  |  |  |  |  |  |  |  |  |
|  | 0B | **General Activities** |  |  | 2012-08-02 | 2012-08-02 |  |  |  |  |  |  |  |  |  |  |  |  |  |  |  |  |  |  |  |  |  |  |  |  |  |  |  |  |  |  |  |  |  |  |  |  |  |  |  |  |  |  |  |  |  |  |  |  |  |  |  |  |  |  |
| X0105600 |  | CA56 General - Mechanical Completion | milestone | 0d | 2012-08-02 | 2012-08-02 | XC605601, A1010300, XJ525601, XV505601 FF, XE705601, X0105610, XE915601, XE505601 FF |  |  |  |  | 22.5d | 149d |  | TB26 - 2 - Manuf and Delivy |  |  |  |  |  |  |  | X0105600 | 0 | 0 | 934 | 56 | 200 | 200 | C | LND | X | 0B | X010 | 5600 | 0 | 56 | X | MC | LND | 5600 |  |  |  |  |  |  |  |  |  |  |  |  |  |  |  |  | XNK | 2DC8990 |  |
| X0105610 |  | CA56 General - Construction Completion | milestone | 0d | 2012-08-02 | 2012-08-02 | XE705601, XC305601, XR405601, XE805601, XC605601, XE915601, XC195601, XN205601, A1010300, XE505601, XJ525601 |  |  |  |  | -32.5d | 0d |  | TB26 - 2 - Manuf and Delivy |  |  |  |  |  |  |  | X0105610 | 0 | 0 | 934 | 56 | 200 | 200 | C | LND | X | 0B | X010 | 5600 | 0 | 56 | X | MC | LND | 5600 |  |  |  |  |  |  |  |  |  |  |  |  |  |  |  |  | XNK | 2DC8990 |  |
|  | C | **Civil Work** |  |  | 2008-09-24 | 2012-03-19 |  |  |  |  |  |  |  |  |  |  |  |  |  |  |  |  |  |  |  |  |  |  |  |  |  |  |  |  |  |  |  |  |  |  |  |  |  |  |  |  |  |  |  |  |  |  |  |  |  |  |  |  |  |  |
| XC115601 |  | CA56 SR5601 - Excavation&Surface Prep by U/I/O |  | 294d | 2008-09-24 A | 2009-09-30 A | XC113100 SS | 100% |  |  |  |  |  |  |  |  |  |  |  |  |  |  | XC115601 | 0 | 0 | 934 | 56 | 200 | 200 | C | UIO | X | C | XC11 | 5601 | C | 56 | X | CW | LND | 5601 | MO11 |  |  |  |  |  |  |  |  |  |  |  |  |  |  |  |  |  |  |
| XC11560105 |  | CA56 SR5601 - Excavation |  | 7d | 2010-05-26 A | 2010-06-02 A | XC11170005 | 100% |  |  |  |  |  |  |  | Excavation [2200 cbm]; Excavation [1100 h] | 88,000 | 88,000 | 1100,00 |  |  |  | XC11560105 | 1100 | 1100 | 934 | 56 | 200 | 200 | C | MO02 | X | C | XC11 | 5601 | C | 10 | X | P | LND | 1010 | MO11 |  |  |  |  |  |  |  |  |  |  |  |  |  |  |  |  | 999 |  |
| XC11560110 |  | CA56 SR5601 - SubBase (Gravel/Geogrid) for Concrete |  | 4d | 2010-06-03 A | 2010-06-08 A | XC11560105 | 100% |  | 2010-06-03 | 2010-06-07 |  |  |  |  | Sub Base for Concrete/Paving&Roads (Gravel) [200 cbm]; Subbase for Concrete [200 h] | 20,000 | 5,000 | 200,00 |  |  |  | XC11560110 | 200 | 200 | 934 | 56 | 200 | 200 | C | MO02 | X | C | XC11 | 5601 | C | 10 | X | P | LND | 1010 | MO11 |  |  |  |  |  |  |  |  |  |  |  |  |  |  |  |  | 999 |  |
| XC155601 |  | CA56 SR5601 - Piling |  | 4d | 2010-06-09 A | 2010-06-12 A | F2910, XC11560105 FS+5d, XC155503 SS, EC155601 (other project) FS+10d, XC115601, XC11560110 | 100% |  |  |  |  |  |  |  | Piles driven [40 pcs]; Piles driven [300 h] | 59.13 |  | 300,00 |  |  |  | XC155601 | 300 | 300 | 934 | 56 | 200 | 200 | C | MO02 | X | C | XC15 | 5601 | C | 56 | X | P | LND | 5601 | MO11 |  |  |  |  |  |  |  |  |  |  |  |  |  |  |  |  |  |  |
| XC205601 |  | CA56 SR5601 - Concrete Works |  | 52d | 2010-09-20 A | 2010-11-19 A | XC205503 SS, P3C02D2 (other project) FS+10d, EC285601 (other project) FS+10d, XC155601, EC45560105 (other project) | 100% |  |  |  |  |  |  |  | Concrete works [80 cbm]; Concrete works [2400 h] | 96,000 | 96,000 | 2400,00 |  |  |  | XC205601 | 2400 | 2400 | 934 | 56 | 200 | 200 | C | MO04 | X | C | XC20 | 5601 | C | 56 | X | mis | LND | 5601 | MO11 |  |  |  |  |  |  |  |  |  |  |  |  |  |  |  |  |  |  |
| XC305601 |  | CA56 SR5601 - UG Installation (incl. Precast Manholes) |  | 80d | 2011-09-19 | 2011-12-21 | P3R02AS1 (other project), IMS-C-000040 FF, XC310C00, P3R02S1 (other project), EC305601 (other project) FS+20d, ER445601 (other project), XC300C00, XC205601, P3R02BS (other project) |  |  |  |  | -56d | 28d | start on or after 2011-09-19 |  |  |  |  |  |  |  |  | XC305601 | 400 | 0 | 934 | 56 | 200 | 200 | C | CiC | X | C | XC30 | 5601 | C | 56 | X | mis | LND | 5601 |  |  |  |  |  |  |  |  |  |  | 27.8. |  |  |  |  |  |  |  | 1 |
| XC195601 |  | CA56 SR5601 - Backfill |  | 10d | 2011-11-15 | 2012-03-01 | XC205601, XC305601 SS+20d, XC915601 FF, IMS-C-000040 FF, XC305601 FF+10d |  |  |  |  | -21d | 0d |  | TB26 - T - Construct-Winter-3 (Dec/Jan/Feb free) * | Backfill & Compaction [900 cbm]; Backfill & Compaction [1350 h] | 81,000 |  | 1350,00 |  |  |  | XC195601 | 1350 | 0 | 934 | 56 | 200 | 200 | C | MO04 | X | C | XC19 | 5601 | C | 56 | X | mis | LND | 5601 | MO11 |  |  |  |  |  |  |  |  |  |  |  |  |  |  |  |  |  |  |
| XC605601 |  | CA56 SR5601 - Paving |  | 15d | 2012-03-01 | 2012-03-19 | XC195601, XN205601 |  |  |  |  | 86d | 113.5d |  |  | Gravel | 1,570.56 |  | 0,00 |  |  |  | XC605601 | 0 | 0 | 934 | 56 | 200 | 200 | C | MO04 | X | C | XC60 | 5601 | C | 56 | X | PV | LND | 5601 | MO11 |  |  |  |  |  |  |  |  |  |  |  |  |  |  |  |  |  | 1 |

Notes:
- XE915503: UDF_PREDECESSOR: XN30, DEL XE40, DEL XE80, DEL XJ40, Civil 100%, Equipment 100%
- XE405503: UDF_PREDECESSOR: XN30, Piping 50%
- XC705503: UDF_PREDECESSOR: XE40, Civil 100%, HVAC ducts, Finishing works partly
- XE805503: UDF_PREDECESSOR: XR40, Piping 50% pressure tests
- XE505503: UDF_PREDECESSOR: XE40, XE50, DEL XE34
- XJ425503: UDF_PREDECESSOR: XE40, XJ32, Equipment 100%, Piping 50%
- XJ525503: UDF_PREDECESSOR: XE40, XJ32, XJ52
- XW505503: P3 Activity Log Info: Clarification Surface Protection during Prefab
- XC115601: P3 Activity Log Info: incl. Dewatering/Drainage
- XC155601: P3 Activity Log Info: 40 driven piles expected,20/d/machine
- XC305601: P3 Activity Log Info: Clarification Prefab Catch Basins/pulling / pits / Current Status: 12.0.2011 (O. Siegel): nach Rьcksprache mit MO11 am 11 und / 12.Januar 11, wurde der 25-April-11 als Starttermin besprochen.

| ID | WBS | Activity | Type | Duration | Start | Finish | Predecessors | Complete | Remaining | Total float | Free float | Constraint | Calendar | Resources | Cost | Actual cost | TB26 Ressource Budget | UDF_SAVE ACT ID | UDF_CHECK BASELINE | UDF_BUDGETED LABOR UNIT | UDF_ACTUAL LABOR UNIT | Department | Type of Work | Constr. Area | PMT-Area | PMT-Schedule Org | PMT-Phase | PMT-Respons. | Zeigen/n. Zeigen | WBS Phase | WBS Discipline | WBS Type of Work | WBS Objects | Russia WBS Discipline (Russia) | Russia Construction Area | Russia WBS Phase | IMS | UPT | Russia WBS Objects | UDF_CONTRACT ITEM | TB26 Semantics | UDF_ELECTRICAL SEQUENCE | Subcontractor | UDF_CONTRACT INDICATOR | UDF_SELECT UPDATE PROGRESS | UDF_CHECK RESOURCE DATES | UDF_COMMENTS_0827 | Inquiry/Order No | UDF_CONTRACT START DATE | UDF_PLANNED START | UDF_CONTRACT FINISH DATE | UDF_PLANNED FINISH | UDF_CHECK CRITICAL PATH | TB26 Material Res Values | UDF_ELECTRICAL START | UDF_ELECTRICAL FINISH | UDF_CONTRACT FINISH DATE REV1 | UDF_CONTRACT START DATE REV1 | UDF_INDICATOR | UDF_Vendor Representatives |
| --- | --- | --- | --- | --- | --- | --- | --- | --- | --- | --- | --- | --- | --- | --- | --- | --- | --- | --- | --- | --- | --- | --- | --- | --- | --- | --- | --- | --- | --- | --- | --- | --- | --- | --- | --- | --- | --- | --- | --- | --- | --- | --- | --- | --- | --- | --- | --- | --- | --- | --- | --- | --- | --- | --- | --- | --- | --- | --- | --- | --- |
|  | N | **Structural Steel** |  |  | 2011-03-10 | 2011-12-24 |  |  |  |  |  |  |  |  |  |  |  |  |  |  |  |  |  |  |  |  |  |  |  |  |  |  |  |  |  |  |  |  |  |  |  |  |  |  |  |  |  |  |  |  |  |  |  |  |  |  |  |  |  |  |
| XN705601 |  | CA56 SR5601 - KMD Assy Drawings | milestone | 0d | 2011-03-10 A | 2011-03-10 A |  | 100% |  |  |  | finish on 2011-03-10 |  |  |  |  | 22t | XN705601 | x | 0 | 0 | 934 | XNK | 56 | 200 | 200 | C | LND | KMD | X | N | XN05 | 5601 | N | 56 | X | PR | LND | 5601 |  |  |  |  |  |  |  |  |  |  |  |  |  |  |  |  |  |  |  |  |  |
| XN715601 |  | CA56 SR5601 - Steel Deliveries | milestone | 0d | 2011-03-27 A | 2011-03-27 A |  | 100% |  |  |  | finish on or after 2011-03-18 | TB26 - 3 - Construction Normal 7days * CA17 |  |  |  | 22t | XN715601 |  | 0 | 0 | 934 | XNK | 56 | 200 | 200 | C | LND | SD | X | N | XN06 | 5601 | N | 56 | X | PR | LND | 5601 |  |  |  |  |  |  |  |  |  |  |  |  |  |  |  |  |  |  |  |  |  |
| XN205601 |  | CA56 SR5601 - Installation Steel Structure |  | 30d | 2011-11-21 | 2011-12-24 | XN205503 SS+5d, XC915601, P3N01JN (other project), XB50311010, P3N012D (other project) FS+10d, XN715601 FS+10d, XN705601, EN685601 (other project), XC195601 FS-80d |  |  | -99d | 0d | start on or after 2011-11-21 |  | Piperacks, Main Structures [42 t]; Grating [100 sqm]; Piperacks, Main structures [1785 h]; Grating [375 h] | 86,400 |  | 2160,00 | XN205601 |  | 2160 | 0 | 934 | XNK | 56 | 200 | 200 | C | LND |  | X | N | XN20 | 5601 | N | 56 | X | PR | LND | 5601 | E-04-35 | t | Plot plan | OMUS-1 |  |  |  |  |  |  |  |  |  |  |  |  |  |  |  |  |  |
|  | H | **HVAC** |  |  |  |  |  |  |  |  |  |  |  |  |  |  |  |  |  |  |  |  |  |  |  |  |  |  |  |  |  |  |  |  |  |  |  |  |  |  |  |  |  |  |  |  |  |  |  |  |  |  |  |  |  |  |  |  |  |  |
|  | U | **Package Units** |  |  |  |  |  |  |  |  |  |  |  |  |  |  |  |  |  |  |  |  |  |  |  |  |  |  |  |  |  |  |  |  |  |  |  |  |  |  |  |  |  |  |  |  |  |  |  |  |  |  |  |  |  |  |  |  |  |  |
|  | B | **Mechanical - Stationary Equipment** |  |  |  |  |  |  |  |  |  |  |  |  |  |  |  |  |  |  |  |  |  |  |  |  |  |  |  |  |  |  |  |  |  |  |  |  |  |  |  |  |  |  |  |  |  |  |  |  |  |  |  |  |  |  |  |  |  |  |
|  | M | **Mechanical - Rotating Equipment** |  |  |  |  |  |  |  |  |  |  |  |  |  |  |  |  |  |  |  |  |  |  |  |  |  |  |  |  |  |  |  |  |  |  |  |  |  |  |  |  |  |  |  |  |  |  |  |  |  |  |  |  |  |  |  |  |  |  |
|  | R | **Piping** |  |  | 2011-04-22 | 2012-03-21 |  |  |  |  |  |  |  |  |  |  |  |  |  |  |  |  |  |  |  |  |  |  |  |  |  |  |  |  |  |  |  |  |  |  |  |  |  |  |  |  |  |  |  |  |  |  |  |  |  |  |  |  |  |  |
| XR205601 |  | CA56 SR5601 - Piping Prefabrication |  | 127d | 2011-04-22 A | 2011-09-20 | P3R06AS1 (other project), P3R06AS (other project) FF+10d, ER495601 (other project), ER49560105 (other project) |  | 21d | -28d | 0d |  |  | A/G piping prefabrication [300 Fpi]; Conveying S. piping prefabrication [250 Fpi]; A/G Piping (Prefab) [1125 h]; Conveying system (Prefab) [625 h] | 26,951.19 | 10,000 | 1750,00 | XR205601 |  | 1750 | 1249,230769 | 934 |  | 56 | 200 | 200 | C | LND |  | X | R | XR20 | 5601 | R | 56 | X | PRP | LND | 5601 |  |  |  | OMUS-1 | UDF_G4 | 27.8. | x | finish mid of september | 2DC8990 |  |  |  |  |  |  |  |  |  |  |  |  |
| XR405601 |  | CA56 SR5601 - Piping Installation |  | 45d | 2011-12-26 | 2012-02-22 | ER475601 (other project) FS-20d, XR205601 SS+30d, XN205601, IMS-C-000190 FF, XW505601 |  |  | -99d | 0d |  |  | A/G piping field installation [400 Fpi]; Conveying S. piping field installation [260 Fpi]; A/G Piping (Field) [2500 h]; Conveying system (Field) [1300 h] | 45,947.43 |  | 3800,00 | XR405601 |  | 3800 | 0 | 934 |  | 56 | 200 | 200 | C | LND |  | X | R | XR40 | 5601 | R | 56 | X | PI | LND | 5601 | E-06-03-13 |  |  | OMUS-1 |  |  |  |  | 2DC8990 | 2011-02-07 | 2011-06-16 |  |  |  |  |  |  |  |  |  |  |
| XR605601 |  | CA56 SR5601 - Piping Pressure Tests |  | 30d | 2012-02-02 | 2012-03-09 | XR405601 FF+12d, X0300020 |  |  | -99d | 0d |  |  |  |  |  | 260 | XR605601 |  | 0 | 0 | 934 |  | 56 | 200 | 200 | C | LND |  | X | R | XR60 | 5601 | R | 56 | X | HY | LND | 5601 | E-06-03-13 |  |  | OMUS-1 |  |  |  |  | 2DC8990 |  |  |  |  |  |  |  |  |  |  |  |  |
| XR805601 |  | CA56 SR5601 - Piping Reinstatement |  | 20d | 2012-02-27 | 2012-03-21 | XR605601 FF+10d, IMS-C-000360 FF |  |  | 315.5d |  |  |  |  |  |  | 130 | XR805601 |  | 0 | 0 | 934 |  | 56 | 200 | 200 | C | LND |  | X | R | XR80 | 5601 | R | 56 | X | PI | LND | 5601 | E-06-03-13 |  |  | OMUS-1 |  |  |  |  |  |  |  | 2011-06-30 | 2011-11-01 |  |  |  |  |  |  |  |  |
|  | E | **Electrical** |  |  | 2010-09-25 | 2012-08-02 |  |  |  |  |  |  |  |  |  |  |  |  |  |  |  |  |  |  |  |  |  |  |  |  |  |  |  |  |  |  |  |  |  |  |  |  |  |  |  |  |  |  |  |  |  |  |  |  |  |  |  |  |  |  |
| XC915601 |  | CA56 SR5601 - Installation Earthing Foundations_CIVIL |  | 61d | 2010-09-25 A | 2010-12-29 A | XC205601 FF+10d, IMS-C-000230 FF, EE905601 (other project) | 100% |  |  |  |  | TB26 - V - Construct-Winter partly * | Grounding & Lightning [120 pcs]; Grounding & Lightning [1350 h] | 54,000 | 54,000 | 1350,00 | XC915601 |  | 1350 | 1350 | 934 |  | 56 | 200 | 200 | C | LND |  | X | C | XE91 | 5601 | C | 56 | X | EA | LND | 5601 | E-16-07-17 |  |  | MO11 |  |  |  |  |  | 2011-03-20 |  | 2011-08-30 |  |  |  |  |  |  |  |  |  |
| XE405601 |  | CA56 SR5601 - Install Cable Trays |  | 30d | 2011-12-26 | 2012-02-04 | XN205601, EE46560110 (other project) |  |  | -5d | 0d |  |  | Cable trays/conduits [250 m]; Cable trays [750 h] | 30,000 |  | 750,00 | XE405601 | x | 750 | 0 | 934 |  | 56 | 200 | 200 | C | LND |  | X | E | XE40 | 5601 | E | 56 | X | EL | LND | 5601 | E-15-01-06 | m | Plot plan, zu spaet !! | URMA |  |  |  |  |  | 2011-05-30 |  | 2011-06-30 |  | Delete Pred Piping Installation | 1255 | 2011-07-09 | 2011-09-05 | 2012-01-15 | 2011-09-15 | UDF_G2 |  |
| XE705601 |  | CA56 SR5601 - Install Lighting & Small Power |  | 40d | 2011-12-26 | 2012-02-16 | EE76510110 (other project), XP341610 FS+50d, P3E03S2 (other project) FF+20d, XE405601 FS-30d, P3E09S (other project), EE765601 (other project) |  |  | 111d | 138.5d |  |  | Cable Pulling [1000 m]; Lighting illuminates [80 pcs]; Cable pulling [500 h]; Lighting (iluminates) [800 h] | 52,000 |  | 1300,00 | XE705601 |  | 1300 | 0 | 934 |  | 56 | 200 | 200 | C | LND |  | X | E | XE70 | 5601 | E | 56 | X | EL | LND | 5601 | E-16-03-01 |  |  | URMA |  |  |  |  |  | 2011-05-10 |  | 2012-01-31 |  |  |  |  |  | 2012-05-10 | 2011-08-15 | UDF_G2 |  |
| XE915601 |  | CA56 SR5601 - Installation Earthing Foundations_E/I |  | 10d | 2011-12-26 | 2012-01-23 | XN205601 |  |  | 113d | 140.5d |  | TB26 - V - Construct-Winter partly * |  |  |  | 135 | XE915601 |  | 0 | 0 | 934 |  | 56 | 200 | 200 | C | LND |  | X | E | XE91 | 5601 | E | 56 | X | EA | LND | 5601 | E-16-07-17 |  |  | URMA |  |  |  |  |  | 2011-03-20 |  | 2011-08-30 |  |  |  |  |  | 2012-04-10 | 2011-05-23 | UDF_G2 |  |
| XE805601 |  | CA56 SR5601 - Install Heat Tracing |  | 40d | 2012-03-10 | 2012-04-25 | P3E19S (other project), XR605601, E3E1950 (other project), XW505601 FF+20d |  |  | 51d | 0d |  |  | Electrical Heat Tracing [1400 m]; Electrical heat tracing [700 h] | 28,000 |  | 700,00 | XE805601 |  | 700 | 0 | 934 |  | 56 | 200 | 200 | C | LND |  | X | E | XE80 | 5601 | E | 56 | X | HT | LND | 5601 | E-16-04-01 |  |  | URMA |  |  |  |  |  | 2011-06-20 |  | 2012-03-20 |  |  |  |  |  | 2012-06-30 | 2011-09-15 | UDF_G2 | 005 |
| XE505601 |  | CA56 SR5601 - Cable Pulling Electric |  | 50d | 2012-06-04 | 2012-08-02 | P3E15AS (other project), XE405601, XE405502, XE500C01, P3E15CS (other project) FF+20d, XE405501, XE505502 SS, P3E15BS (other project) FF+20d, XE403110, EE565601 (other project) |  |  | -87.5d | 0d |  | TB26 - V - Construct-Winter partly * | Cable Pulling [9700 m]; Cable pulling [4850 h] | 194,000 |  | 4850,00 | XE505601 |  | 4850 | 0 | 934 |  | 56 | 200 | 200 | C | LND |  | X | E | XE50 | 5601 | E | 56 | X | EL | LND | 5601 | E-16-01-01 | m | Plot plan | URMA |  |  |  |  |  | 2011-05-20 |  | 2012-02-10 |  |  | 10020 | 2011-08-29 | 2011-10-25 | 2012-07-01 | 2011-10-01 | UDF_G2 |  |
|  | J | **Instrumentation** |  |  | 2012-01-13 | 2012-07-10 |  |  |  |  |  |  |  |  |  |  |  |  |  |  |  |  |  |  |  |  |  |  |  |  |  |  |  |  |  |  |  |  |  |  |  |  |  |  |  |  |  |  |  |  |  |  |  |  |  |  |  |  |  |  |
| XJ425601 |  | CA56 SR5601 - Install CableTrays Instrumentation |  | 20d | 2012-01-13 | 2012-02-04 | EJ46510120 (other project), XN205601, EJ46560110 (other project), XE405601 FF |  |  | 6d | 98.5d |  |  | Main cable trays [200 m]; Install Main Cable trays [600 h] | 24,000 |  | 600,00 | XJ425601 | x | 600 | 0 | 934 |  | 56 | 200 | 200 | C | LND |  | X | J | XJ42 | 5601 | J | 56 | X | IN | LND | 5601 | E-15-01-06 | m | Plot plan, zu spaet !! | URMA |  |  |  |  |  | 2011-05-30 |  | 2011-06-30 |  |  | 850 | 2011-07-09 | 2011-09-05 | 2012-01-15 | 2011-09-15 | UDF_G2 |  |
| XJ525601 |  | CA56 SR5601 - Pulling Instrument Cables |  | 30d | 2012-06-04 | 2012-07-10 | XJ425601, XE500C01, XJ525502 SS |  |  | -82.5d | 0d |  | TB26 - V - Construct-Winter partly * | Multicore cables [1900 m]; Pull multicore cables [950 h] | 38,000 |  | 950,00 | XJ525601 |  | 950 | 0 | 934 |  | 56 | 200 | 200 | C | LND |  | X | J | XJ52 | 5601 | J | 56 | X | IN | LND | 5601 | E-17-04-17 | m |  | URMA |  |  |  |  |  | 2011-03-20 |  | 2011-09-20 |  |  | 1385 | 2011-09-29 | 2011-12-12 | 2012-03-30 | 2011-08-10 |  |  |
|  | S | **Safety & Environment** |  |  |  |  |  |  |  |  |  |  |  |  |  |  |  |  |  |  |  |  |  |  |  |  |  |  |  |  |  |  |  |  |  |  |  |  |  |  |  |  |  |  |  |  |  |  |  |  |  |  |  |  |  |  |  |  |  |  |
|  | W | **Painting** |  |  | 2011-08-01 | 2011-10-01 |  |  |  |  |  |  |  |  |  |  |  |  |  |  |  |  |  |  |  |  |  |  |  |  |  |  |  |  |  |  |  |  |  |  |  |  |  |  |  |  |  |  |  |  |  |  |  |  |  |  |  |  |  |  |
| XW505601 |  | CA56 SR5601 - Surf.Protection Piping |  | 54d | 2011-08-01 A | 2011-10-01 | XR205601 FF+10d |  | 31d | -28d | 71d |  |  | Piping painting [325 sqm]; Piping painting [813 h] | 793.78 |  | 813,00 | XW505601 |  | 813 | 0 | 934 |  | 56 | 200 | 200 | C | LND |  | X | W | XW50 | 5601 | W | 56 | X | PA | LND | 5601 |  |  |  | OMUS-1 |  | 27.8. | x |  |  |  |  |  |  |  |  |  |  |  |  |  |  |

Notes:
- XN715601: Scope: 09.02.2011: weight: 50 ton
- XN205601: P3 Activity Log Info: Clarification Preassembly / Current Status: 20110720 (O.Siegel): accordant / to the Crane Position Conception from Konrad Bucher from July / 2011: Crane MC 250 will need a access from 01.08.2011 to / 20.11.11. So the CA56 can not be installed before.
- XE405601: Current Status: Delete PRED XR405601 Piping Installation SS+40 / UDF_PREDECESSOR: XN30, Piping 50%
- XE705601: UDF_PREDECESSOR: XE40, Civil 100%, HVAC ducts, Finishing works partly
- XE915601: UDF_PREDECESSOR: XN30, DEL XE40, DEL XE80, DEL XJ40, Civil 100%, Equipment 100%
- XE805601: UDF_PREDECESSOR: XR40, Piping 50% pressure tests
- XE505601: UDF_PREDECESSOR: XE40, XE50, DEL XE34
- XJ425601: UDF_PREDECESSOR: XE40, XJ32, Equipment 100%, Piping 50%
- XJ525601: UDF_PREDECESSOR: XE40, XJ32, XJ52
- XW505601: P3 Activity Log Info: Clarification Surface Protection during Prefab

| ID | WBS | Activity | Type | Duration | Start | Finish | Predecessors | Total float | Free float | Constraint | Calendar | Resources | Cost | TB26 Ressource Budget | UDF_CONTRACT FINISH DATE | UDF_CONTRACT ITEM | UDF_CONTRACT DATE PENALIZED | UDF_PENALIZED START | UDF_PENALIZED FINISH | UDF_SAVE ACT ID | UDF_BUDGETED LABOR UNIT | UDF_ACTUAL LABOR UNIT | Department | Constr. Area | Inquiry/Order No | PMT-Area | PMT-Schedule Org | PMT-Phase | PMT-Respons. | WBS Phase | WBS Discipline | WBS Type of Work | WBS Objects | Russia WBS Discipline (Russia) | Russia Construction Area | Russia WBS Phase | IMS | UPT | Russia WBS Objects | Subcontractor | Filter | UDF_Actictity Name (Russia) | Zeigen/n. Zeigen |
| --- | --- | --- | --- | --- | --- | --- | --- | --- | --- | --- | --- | --- | --- | --- | --- | --- | --- | --- | --- | --- | --- | --- | --- | --- | --- | --- | --- | --- | --- | --- | --- | --- | --- | --- | --- | --- | --- | --- | --- | --- | --- | --- | --- |
|  | V | **Insulation** |  |  | 2012-04-26 | 2012-06-26 |  |  |  |  |  |  |  |  |  |  |  |  |  |  |  |  |  |  |  |  |  |  |  |  |  |  |  |  |  |  |  |  |  |  |  |  |  |
| XV505601 |  | CA56 SR5601 - Insulation Piping |  | 50d | 2012-04-26 | 2012-06-26 | XE805601, XE805601 FF+20d, XR605601 SS | 51d | 31.5d |  | TB26 - V - Construct-Winter partly * | Piping insulation [300 sqm]; Piping insulation [2250 h] | 3,222.42 | 2250,00 | 2012-04-30 | E-13-01 | P | 2012-04-30 | 2012-04-30 | XV505601 | 2250 | 0 | 934 | 56 | 2DC8990 | 200 | 200 | C | LND | X | V | XV50 | 5601 | V | 56 | X | INS | LND | 5601 | OMUS-1 |  |  |  |
|  | 90 | **CA90 - Underground Piping** |  |  |  |  |  |  |  |  |  |  |  |  |  |  |  |  |  |  |  |  |  |  |  |  |  |  |  |  |  |  |  |  |  |  |  |  |  |  |  |  |  |
|  | 96 | **CA96 - Roads / Paving** |  |  | 2012-04-02 | 2012-07-30 |  |  |  |  |  |  |  |  |  |  |  |  |  |  |  |  |  |  |  |  |  |  |  |  |  |  |  |  |  |  |  |  |  |  |  |  |  |
| XC111196005 |  | CA96 General - Excavation |  | 100d | 2012-04-02 | 2012-07-30 |  | 206.5d |  | start on or after 2012-04-02 |  | Excavation [55603 cbm]; Excavation [27801.5 h] | 2,224,120 | 27801,50 |  |  |  |  |  | XC111196005 | 27801,5 | 0 | 934 | 96 | 999 | 200 | 200 | C | MO02 | X | C | XC11 | 9600 | C | 10 | X | P | LND | 96 |  | 1 |  |  |
|  | 98 | **CA98 - Miscellaneous** |  |  |  |  |  |  |  |  |  |  |  |  |  |  |  |  |  |  |  |  |  |  |  |  |  |  |  |  |  |  |  |  |  |  |  |  |  |  |  |  |  |
|  | 99 | **CA99 - Existing** |  |  |  |  |  |  |  |  |  |  |  |  |  |  |  |  |  |  |  |  |  |  |  |  |  |  |  |  |  |  |  |  |  |  |  |  |  |  |  |  |  |
|  | OV | **Overall** |  |  |  |  |  |  |  |  |  |  |  |  |  |  |  |  |  |  |  |  |  |  |  |  |  |  |  |  |  |  |  |  |  |  |  |  |  |  |  |  |  |
|  | Y | **Precommissioning** |  |  | 2011-11-29 | 2013-04-10 |  |  |  |  |  |  |  |  |  |  |  |  |  |  |  |  |  |  |  |  |  |  |  |  |  |  |  |  |  |  |  |  |  |  |  |  |  |
|  | 0Y | **0Y Precommissioning** |  |  | 2011-11-29 | 2013-04-10 |  |  |  |  |  |  |  |  |  |  |  |  |  |  |  |  |  |  |  |  |  |  |  |  |  |  |  |  |  |  |  |  |  |  |  |  |  |
|  | 0000 | **0000 Generals - all CA's** |  |  | 2011-11-29 | 2013-04-10 |  |  |  |  |  |  |  |  |  |  |  |  |  |  |  |  |  |  |  |  |  |  |  |  |  |  |  |  |  |  |  |  |  |  |  |  |  |
|  | 0B | **0B General Activities** |  |  | 2011-11-29 | 2013-04-10 |  |  |  |  |  |  |  |  |  |  |  |  |  |  |  |  |  |  |  |  |  |  |  |  |  |  |  |  |  |  |  |  |  |  |  |  |  |
| YY0100 |  | Utilities Supply & Precommissioning pre- MC activities | level of effort | 327.5d | 2011-11-29 | 2012-12-31 | X0300035 FF, X0300070 FF, X0300030 FF, X0300050 FF, X0300005 SS, X0300085 FF, X0300055 FF, X0300015 FF, X0300040 FF, X0300065 FF, X0300045 FF | 78d | 0d |  |  |  |  |  |  |  |  |  |  | YY0100 | 0 | 0 | 010 | 0Y |  | 200 | 200 | S | LND | Y | 0B | X030 | 0000 |  |  |  | MC | LND |  |  |  | Поставка ОЗХ и пуско-наладочные работы | M1 |
| YY0110 |  | Handover PP Plant Systems |  | 78d | 2012-12-31 | 2013-04-10 | X0051700 FF, XX0100, IMS-LND-MC-00010 (other project) FF, XX120 | 0d |  |  |  |  |  |  |  |  |  |  |  | YY0110 | 0 | 0 | 010 | 0Y |  | 200 | 200 | S | LND | Y | 0B | X030 | 0000 |  |  |  | CSS | LND |  |  |  | Сдача систем комплекса по производству ПП | M1 |
|  | Y | **Y Precommissioning** |  |  | 2012-12-31 | 2013-02-25 |  |  |  |  |  |  |  |  |  |  |  |  |  |  |  |  |  |  |  |  |  |  |  |  |  |  |  |  |  |  |  |  |  |  |  |  |  |
| INEOS100 |  | Check Electrical Loops |  | 7d | 2012-12-31 | 2013-01-07 | XE601111, XE601740, XE601301, XX0100, XX120, XE601222, XE601730, XE601233, XE603140, XE601321 | 44d | 0d |  | 0 G-7-day work 24h/day |  |  |  |  |  |  |  |  | INEOS100 | 0 | 0 | 010 | 0Y |  | 200 | 200 | S | PMT | Y | Y | YY10 | 0000 |  |  |  | E | LND |  |  |  | Сдача систем комплекса по производству ПП |  |
| INEOS105 |  | Check Instrument Loops |  | 7d | 2012-12-31 | 2013-01-07 | XJ801720, XJ801740, XJ803140, XJ804100, XJ801322, XJ801330, XX120, XJ801233, XJ803110, XJ800C00, XJ801230, XJ801710, XJ801730, XJ801332, XJ801222, XJ801610, XJ801010, XJ801301, XX0100, XJ801110, XJ801201, XJ801510, XJ801111, XJ801221, XJ801410, XJ801130, XJ801321, XJ801718, XJ801736, XJ80176005, XJ801232, XJ801760, XJ803120 | 44d | 0d |  | 0 G-7-day work 24h/day |  |  |  |  |  |  |  |  | INEOS105 | 0 | 0 | 010 | 0Y |  | 200 | 200 | S | PMT | Y | Y | YY10 | 0000 |  |  |  | E | LND |  |  |  | Сдача систем комплекса по производству ПП |  |
| INEOS110 |  | Run disconnected Motors |  | 7d | 2013-01-07 | 2013-01-14 | INEOS100, INEOS105 | 44d | 0d |  | 0 G-7-day work 24h/day |  |  |  |  |  |  |  |  | INEOS110 | 0 | 0 | 010 | 0Y |  | 200 | 200 | S | PMT | Y | Y | YY10 | 0000 |  |  |  | E | LND |  |  |  | Сдача систем комплекса по производству ПП |  |
| INEOS115 |  | Check interlocks and ESD Loops |  | 14d | 2013-01-14 | 2013-01-28 | INEOS110 | 72d |  |  | 0 G-7-day work 24h/day |  |  |  |  |  |  |  |  | INEOS115 | 0 | 0 | 010 | 0Y |  | 200 | 200 | S | PMT | Y | Y | YY10 | 0000 |  |  |  | E | LND |  |  |  | Сдача систем комплекса по производству ПП |  |
| INEOS120 |  | Precom Extruders |  | 14d | 2013-01-14 | 2013-01-28 | INEOS110 | 44d | 0d |  | 0 G-7-day work 24h/day |  |  |  |  |  |  |  |  | INEOS120 | 0 | 0 | 010 | 0Y |  | 200 | 200 | S | PMT | Y | Y | YY10 | 0000 |  |  |  | E | LND |  |  |  | Сдача систем комплекса по производству ПП |  |
| INEOS125 |  | Precom Offgas Compressors |  | 7d | 2013-01-28 | 2013-02-04 | INEOS120 | 44d | 0d |  | 0 G-7-day work 24h/day |  |  |  |  |  |  |  |  | INEOS125 | 0 | 0 | 010 | 0Y |  | 200 | 200 | S | PMT | Y | Y | YY10 | 0000 |  |  |  | E | LND |  |  |  | Сдача систем комплекса по производству ПП |  |
| INEOS130 |  | Precom Recycle Gas Compressors (RGC) |  | 7d | 2013-02-04 | 2013-02-11 | INEOS125, X0300055 | 44d | 0d |  | 0 G-7-day work 24h/day |  |  |  |  |  |  |  |  | INEOS130 | 0 | 0 | 010 | 0Y |  | 200 | 200 | S | PMT | Y | Y | YY10 | 0000 |  |  |  | E | LND |  |  |  | Сдача систем комплекса по производству ПП |  |
| INEOS135 |  | Precom PRU |  | 7d | 2013-02-11 | 2013-02-18 | X0300050, INEOS130, X0300045, X0101000 | 44d | 0d |  | 0 G-7-day work 24h/day |  |  |  |  |  |  |  |  | INEOS135 | 0 | 0 | 010 | 0Y |  | 200 | 200 | S | PMT | Y | Y | YY10 | 0000 |  |  |  | E | LND |  |  |  | Сдача систем комплекса по производству ПП |  |
| INEOS140 |  | Calibrate RGC Antisurge Controller |  | 7d | 2013-02-18 | 2013-02-25 | INEOS135 | 44d |  |  | 0 G-7-day work 24h/day |  |  |  |  |  |  |  |  | INEOS140 | 0 | 0 | 010 | 0Y |  | 200 | 200 | S | PMT | Y | Y | YY10 | 0000 |  |  |  | E | LND |  |  |  | Сдача систем комплекса по производству ПП |  |

Notes:
- YY0100: P3 Activity Log Info: incl. start activities HVAC, alle required hand overs sytem activities, / function tests

| ID | WBS | Activity | Duration | Start | Finish | Predecessors | Total float | Free float | Calendar | UDF_Actictity Name (Russia) | UDF_SAVE ACT ID | UDF_BUDGETED LABOR UNIT | UDF_ACTUAL LABOR UNIT | Department | Constr. Area | PMT-Area | PMT-Schedule Org | PMT-Phase | PMT-Respons. | WBS Phase | WBS Discipline | WBS Type of Work | WBS Objects | IMS | UPT |
| --- | --- | --- | --- | --- | --- | --- | --- | --- | --- | --- | --- | --- | --- | --- | --- | --- | --- | --- | --- | --- | --- | --- | --- | --- | --- |
|  | Z | **Commissioning** |  | 2012-12-31 | 2013-02-27 |  |  |  |  |  |  |  |  |  |  |  |  |  |  |  |  |  |  |  |  |
|  | 0Z | **0Z Commissioning** |  | 2012-12-31 | 2013-02-27 |  |  |  |  |  |  |  |  |  |  |  |  |  |  |  |  |  |  |  |  |
|  | 0000 | **0000 Generals - all CA's** |  | 2012-12-31 | 2013-02-27 |  |  |  |  |  |  |  |  |  |  |  |  |  |  |  |  |  |  |  |  |
|  | I | **I Ineos Activities** |  | 2012-12-31 | 2013-02-27 |  |  |  |  |  |  |  |  |  |  |  |  |  |  |  |  |  |  |  |  |
| INEOS300 |  | Commission Steam System | 2d | 2012-12-31 | 2013-01-02 | XH00111005, XH00313010, XH00314010, XH00171805, XH00171810, XH00173005, XH00122210, XH00161005, XH00171005, XH00311010, XX0100, XH00171010, XH00172010, XH00312010, XH00132210, XH00161007, XH00161010, XH00173610, XH00111010, XH00122110, XH00173010, XH00132110, XX120, XH00122105, XH00312005, XH001610050, XH00161007_1, XH00311005_1 | 17d | 0d | 0 G-7-day work 24h/day | Сдача систем комплекса по производству ПП | INEOS300 | 0 | 0 | 010 | 0Z | 200 | 200 | S | PMT | Z | I | YY10 | 0000 | E | LND |
| INEOS305 |  | Commission CW System | 3d | 2013-01-02 | 2013-01-05 | INEOS300 | 17d | 0d | 0 G-7-day work 24h/day | Сдача систем комплекса по производству ПП | INEOS305 | 0 | 0 | 010 | 0Z | 200 | 200 | S | PMT | Z | I | YY10 | 0000 | E | LND |
| INEOS310 |  | Commission Conveying System | 40d | 2013-01-05 | 2013-02-14 | E-21502, K-21502 A/B, XX-21501, F-22401, XR401736, XR403110, XM103120, XX-21501-BL01, XR405501, INEOS305, F-21405, F-21404, BG-21435, BG-22402, BG-22405, XB003120, F-21408, F-22404, RF-21403, F-22405, RF-22401, RF-22404, BG-22403, V-21502, XX-22501-RF01, BL-22402, XX-22401, RF-21407, RF-22405, F-22407, BG-21404, BG-21407, BG-22407, XR405503, V-22502, XX-21401, F-22403, F-21401, RF-21405, RF-21402, RF-21434, F-21403, BG-21401, XR401760, XR401720, F-22402, RF-22403, F-21407, RF-21401, BG-21402, BG-22401, XR401740, XX-22501-BL01, E-22502, XR401710, BL-21402A/B, XR401718, RF-21435, RF-22402, RF-22407, BG-21405, BG-21408, MB-21401, MB-22401, BG-22404, BL-21452, RF-21516, K-22502 A/B, F-21402, RF-21408, RF-21404, XR401730, BG-21403, RF-21515, XR405502 | 55d | 0d | 0 G-7-day work 24h/day | Сдача систем комплекса по производству ПП | INEOS310 | 0 | 0 | 010 | 0Z | 200 | 200 | S | PMT | Z | I | YY10 | 0000 | E | LND |
| INEOS320 |  | Commission Seal Oil System | 5d | 2013-01-05 | 2013-01-10 | V-21222, MI-22202, INEOS305, MI-21202, AG-21201, C-21801, E-21203, V-22221, PK-21211, CY-22202, E-22206, V-22223, V-21221, V-21223, AG-22201, V-21224, V-22224, MI-21801, CY-21202, E-21206, E-22203, PK-22211, V-22222 (other project) | 17d | 0d | 0 G-7-day work 24h/day | Сдача систем комплекса по производству ПП | INEOS320 | 0 | 0 | 010 | 0Z | 200 | 200 | S | PMT | Z | I | YY10 | 0000 | E | LND |
| INEOS325 |  | Commission N2 System | 3d | 2013-01-10 | 2013-01-13 | X0300070, INEOS320, X0300065, INEOS305 | 17d | 0d | 0 G-7-day work 24h/day | Сдача систем комплекса по производству ПП | INEOS325 | 0 | 0 | 010 | 0Z | 200 | 200 | S | PMT | Z | I | YY10 | 0000 | E | LND |
| INEOS330 |  | Air-free and Pressure Test's | 3d | 2013-01-13 | 2013-01-16 | INEOS325, X0300035 | 17d | 0d | 0 G-7-day work 24h/day | Сдача систем комплекса по производству ПП | INEOS330 | 0 | 0 | 010 | 0Z | 200 | 200 | S | PMT | Z | I | YY10 | 0000 | E | LND |
| INEOS335 |  | Load Powder into Purge Columns | 3d | 2013-01-16 | 2013-01-19 | X0300030, X0300040, INEOS330 | 17d | 0d | 0 G-7-day work 24h/day | Сдача систем комплекса по производству ПП | INEOS335 | 0 | 0 | 010 | 0Z | 200 | 200 | S | PMT | Z | I | YY10 | 0000 | E | LND |
| INEOS315 |  | Commission Bagging & Packaging System | 28d | 2013-01-17 | 2013-02-14 | XM003110, MI-21501, INEOS310 FF, MI-21502, XM003140, XB003140 | 55d |  | 0 G-7-day work 24h/day | Сдача систем комплекса по производству ПП | INEOS315 | 0 | 0 | 010 | 0Z | 200 | 200 | S | PMT | Z | I | YY10 | 0000 | E | LND |
| INEOS340 |  | Run both Compounders with Powder | 14d | 2013-01-24 | 2013-02-07 | INEOS335 FS+5d | 17d | 0d | 0 G-7-day work 24h/day | Сдача систем комплекса по производству ПП | INEOS340 | 0 | 0 | 010 | 0Z | 200 | 200 | S | PMT | Z | I | YY10 | 0000 | E | LND |
| INEOS355 |  | Calibrate laboratory Instruments | 14d | 2013-02-06 | 2013-02-20 | INEOS350 FF | 17d | 0d | 0 G-7-day work 24h/day | Сдача систем комплекса по производству ПП | INEOS355 | 0 | 0 | 010 | 0Z | 200 | 200 | S | PMT | Z | I | YY10 | 0000 | E | LND |
| INEOS345 |  | Calibrate Reactor Level with Powder | 7d | 2013-02-09 | 2013-02-16 | INEOS340 FS+2d | 17d | 0d | 0 G-7-day work 24h/day | Сдача систем комплекса по производству ПП | INEOS345 | 0 | 0 | 010 | 0Z | 200 | 200 | S | PMT | Z | I | YY10 | 0000 | E | LND |
| INEOS350 |  | Run complete Unit on hot N2 | 4d | 2013-02-16 | 2013-02-20 | INEOS345 | 17d | 0d | 0 G-7-day work 24h/day | Сдача систем комплекса по производству ПП | INEOS350 | 0 | 0 | 010 | 0Z | 200 | 200 | S | PMT | Z | I | YY10 | 0000 | E | LND |
| INEOS360 |  | Fill Unit with Propylene | 3d | 2013-02-20 | 2013-02-23 | INEOS355, INEOS350 | 17d | 0d | 0 G-7-day work 24h/day | Сдача систем комплекса по производству ПП | INEOS360 | 0 | 0 | 010 | 0Z | 200 | 200 | S | PMT | Z | I | YY10 | 0000 | E | LND |
| INEOS365 |  | Circulate Propylene | 4d | 2013-02-23 | 2013-02-27 | X0300050, INEOS360 | 42d |  | 0 G-7-day work 24h/day | Сдача систем комплекса по производству ПП | INEOS365 | 0 | 0 | 010 | 0Z | 200 | 200 | S | PMT | Z | I | YY10 | 0000 | E | LND |
| INEOS370 |  | Charge Catalyst Hold Drum | 2d | 2013-02-23 | 2013-02-25 | INEOS360 | 17d | 0d | 0 G-7-day work 24h/day | Сдача систем комплекса по производству ПП | INEOS370 | 0 | 0 | 010 | 0Z | 200 | 200 | S | PMT | Z | I | YY10 | 0000 | E | LND |
| INEOS375 |  | Attach TEAL Cylinders | 1d | 2013-02-24 | 2013-02-25 | INEOS370 FF | 17d | 0d | 0 G-7-day work 24h/day | Сдача систем комплекса по производству ПП | INEOS375 | 0 | 0 | 010 | 0Z | 200 | 200 | S | PMT | Z | I | YY10 | 0000 | E | LND |
| INEOS380 |  | Attach SILANE Cylinders | 1d | 2013-02-25 | 2013-02-26 | INEOS375 | 17d | 0d | 0 G-7-day work 24h/day | Сдача систем комплекса по производству ПП | INEOS380 | 0 | 0 | 010 | 0Z | 200 | 200 | S | PMT | Z | I | YY10 | 0000 | E | LND |
|  | S | **Start-Up** |  | 2013-02-26 | 2013-03-24 |  |  |  |  |  |  |  |  |  |  |  |  |  |  |  |  |  |  |  |  |
|  | 0Z | **0Z Commissioning** |  | 2013-02-26 | 2013-03-24 |  |  |  |  |  |  |  |  |  |  |  |  |  |  |  |  |  |  |  |  |
|  | 0000 | **0000 Generals - all CA's** |  | 2013-02-26 | 2013-03-24 |  |  |  |  |  |  |  |  |  |  |  |  |  |  |  |  |  |  |  |  |
|  | 0B | **0B General Activities** |  | 2013-03-12 | 2013-03-24 |  |  |  |  |  |  |  |  |  |  |  |  |  |  |  |  |  |  |  |  |
| SS0110 |  | HP Performance Test | 3d | 2013-03-12 | 2013-03-15 | SS0100 | 17d | 0d | 0 G-7-day work 24h/day | Сдача систем комплекса по производству ПП | SS0110 | 0 | 0 | 010 | 0Z | 200 | 200 | S | PMT | S | 0B | YY10 | 0000 | CM | LND |
| SS0120 |  | RCP Operation | 6d | 2013-03-15 | 2013-03-21 | SS0110 | 17d | 0d | 0 G-7-day work 24h/day | Сдача систем комплекса по производству ПП | SS0120 | 0 | 0 | 010 | 0Z | 200 | 200 | S | PMT | S | 0B | YY10 | 0000 | CM | LND |
| SS0130 |  | RCP Performance Test | 3d | 2013-03-21 | 2013-03-24 | SS0120 | 17d |  | 0 G-7-day work 24h/day | Сдача систем комплекса по производству ПП | SS0130 | 0 | 0 | 010 | 0Z | 200 | 200 | S | PMT | S | 0B | YY10 | 0000 | CM | LND |

| ID | WBS | Activity | Duration | Start | Finish | Predecessors | Total float | Free float | Calendar | UDF_Actictity Name (Russia) | UDF_SAVE ACT ID | UDF_BUDGETED LABOR UNIT | UDF_ACTUAL LABOR UNIT | Department | Constr. Area | PMT-Area | PMT-Schedule Org | PMT-Phase | PMT-Respons. | WBS Phase | WBS Discipline | WBS Type of Work | WBS Objects | IMS | UPT |
| --- | --- | --- | --- | --- | --- | --- | --- | --- | --- | --- | --- | --- | --- | --- | --- | --- | --- | --- | --- | --- | --- | --- | --- | --- | --- |
|  | I | **I Ineos Activities** |  | 2013-02-26 | 2013-03-12 |  |  |  |  |  |  |  |  |  |  |  |  |  |  |  |  |  |  |  |  |
| SS0100 |  | HP Operation | 14d | 2013-02-26 | 2013-03-12 | INEOS380 | 17d | 0d | 0 G-7-day work 24h/day | Сдача систем комплекса по производству ПП | SS0100 | 0 | 0 | 010 | 0Z | 200 | 200 | S | PMT | S | I | YY10 | 0000 | CM | LND |
|  | T | **Template per Discipline** |  |  |  |  |  |  |  |  |  |  |  |  |  |  |  |  |  |  |  |  |  |  |  |
|  | 0B | **General Activities** |  |  |  |  |  |  |  |  |  |  |  |  |  |  |  |  |  |  |  |  |  |  |  |
|  | C | **Civil Work** |  |  |  |  |  |  |  |  |  |  |  |  |  |  |  |  |  |  |  |  |  |  |  |
|  | N | **Structural Steel** |  |  |  |  |  |  |  |  |  |  |  |  |  |  |  |  |  |  |  |  |  |  |  |
|  | H | **HVAC** |  |  |  |  |  |  |  |  |  |  |  |  |  |  |  |  |  |  |  |  |  |  |  |
|  | U | **Package Units** |  |  |  |  |  |  |  |  |  |  |  |  |  |  |  |  |  |  |  |  |  |  |  |
|  | B | **Mechanical - Stationary Equipment** |  |  |  |  |  |  |  |  |  |  |  |  |  |  |  |  |  |  |  |  |  |  |  |
|  | M | **Mechanical - Rotating Equipment** |  |  |  |  |  |  |  |  |  |  |  |  |  |  |  |  |  |  |  |  |  |  |  |
|  | R | **Piping** |  |  |  |  |  |  |  |  |  |  |  |  |  |  |  |  |  |  |  |  |  |  |  |
|  | E | **Electrical** |  |  |  |  |  |  |  |  |  |  |  |  |  |  |  |  |  |  |  |  |  |  |  |
|  | J | **Instrumentation** |  |  |  |  |  |  |  |  |  |  |  |  |  |  |  |  |  |  |  |  |  |  |  |
|  | S | **Safety & Environment** |  |  |  |  |  |  |  |  |  |  |  |  |  |  |  |  |  |  |  |  |  |  |  |
|  | W | **Painting** |  |  |  |  |  |  |  |  |  |  |  |  |  |  |  |  |  |  |  |  |  |  |  |
|  | V | **Insulation** |  |  |  |  |  |  |  |  |  |  |  |  |  |  |  |  |  |  |  |  |  |  |  |

## Activity codes

| Code | Value | Meaning |
| --- | --- | --- |
| 4 week lookahead | x | 4 week lookahead meeting |
| Check ResLoading | 31 | CA31 |
| Check ResLoading | UG | UG Underground |
| Check ResLoading | X | SELECT FOR CHECK RESOURCE LOADING |
| Constr. Area | 00 | Construction Areas - General |
| Constr. Area | 0C | Construction Milestones Disciplines |
| Constr. Area | 0Y | Precommissioning |
| Constr. Area | 0Z | Commissioning |
| Constr. Area | 10 | CA10 - Propylene Recovery Unit Area |
| Constr. Area | 11 | CA11 - Offgas Compression Line 1 + 2 |
| Constr. Area | 12 | CA12 - Polymerization Line 1 |
| Constr. Area | 13 | CA13 - Polymerization Line 2 |
| Constr. Area | 14 | CA14 - Flare Area |
| Constr. Area | 15 | CA15 - Instrument Air Buffer Vessel |
| Constr. Area | 16 | CA16 - Substation / RIE's |
| Constr. Area | 17 | CA17 - Extruder Pack / Additive Handling-Line1/2 |
| Constr. Area | 18 | CA18 - Central Chiller Unit Area |
| Constr. Area | 31 | CA31 - Storage / Packaging and Shipping Building |
| Constr. Area | 41 | CA41 - Control Building |
| Constr. Area | 51 | CA51 - Piperack (btw. CA11-15/17/19/52/53/54) |
| Constr. Area | 52 | CA52 - Piperack (between CA11/51) |
| Constr. Area | 53 | CA53 - Piperack (between CA14/51) |
| Constr. Area | 54 | CA54 - Piperack (between CA15/16/51/55) |
| Constr. Area | 55 | CA55 - Piperack (between CA16/17/56) |
| Constr. Area | 56 | CA56 - Piperack (between CA17/31/55) |
| Constr. Area | 96 | Concrete Paving |
| Department | 010 | Precommissioning |
| Department | 860 | Procurement - KB |
| Department | 87A | Civil Engineering - TKBB |
| Department | 934 | Construction Engineering- TME |
| EQPT-Group PP | EX-21401 | Extruder Line 1 |
| EQPT-Group PP | EX-22402 | Extruder Line 2 |
| IMS | AG | Aboveground |
| IMS | B | Bulk |
| IMS | C | CONSTRUCTION |
| IMS | CM | Commissioning |
| IMS | CS | Install Communication System |
| IMS | CSS | COMMISSIONING & START UP |
| IMS | CW | Civil Works |
| IMS | DCS | DCS available |
| IMS | E | Equipment (Static, Rotary, Packages) |
| IMS | E&I | Electrical & Instrumentation Installation |
| IMS | EA | Earthing |
| IMS | EB | Extrusion Building |
| IMS | EL | Installation Electrical |
| IMS | EQ | Install Equipment |
| IMS | ET | Electrical Testing |
| IMS | FGDS | Install F&G Detection System |
| IMS | FP | Fire Proofing |
| IMS | HL | Heavy Lifts |
| IMS | HT | Installation Heat Tracing |
| IMS | HY | Pipe Testing |
| IMS | IN | Installation Instruments |
| IMS | INS | Install Insulation |
| IMS | IT | Itemized |
| IMS | LT | Loop / Functional Testing |
| IMS | M | Main Steel Structure at Site |
| IMS | MC | Mechanical Completion |
| IMS | MI | Mechanical Installation |
| IMS | ML | MANAGEMENT, MILESTONES & COORDINATION |
| IMS | OB | Other Building |
| IMS | P | Piling |
| IMS | PA | Painting (Field) |
| IMS | PI | Installation Piping |
| IMS | PR | Install Pipe Rack Steel Structure |
| IMS | PRP | Prefabrication Piping |
| IMS | PV | Paving & Roads |
| IMS | S | At Site |
| IMS | SS | Substation |
| IMS | UG | Underground |
| IMS | ci | Civil Works Contractor |
| IMS | hva_as | HVAC at Site |
| IMS | hvac | Install HVAC |
| IMS | mai | Foundations (Main) |
| IMS | mis | Pipreack Foundations (Miscellaneous) |
| IMS | pre | Precast Concrete Elements |
| Inquiry/Order No | 2DC8460 | Offgas Compressor Pack. K-21301,K-22301 |
| Inquiry/Order No | 2DC8480 | Extruder Package EX-21401, EX-22401 |
| Inquiry/Order No | 2DC8990 | Conveying System (Zeppelin) |
| Inquiry/Order No | 2DC9000 | Silo's and Blenders |
| Inquiry/Order No | 2DC9010 | Mobile FFS Bagging System BG-31201 |
| Inquiry/Order No | 2DC9020 | Pallet Packaging & Palletizing Equipment |
| Inquiry/Order No | 2DD0330 | Flare Package |
| Inquiry/Order No | 2EB5640 | MV-Switchgears |
| Inquiry/Order No | D01 | General Cargo Subcontract |
| MTA | MTA | MTA General |
| PMT-Area | 200 | Polypropylene Unit (PP) |
| PMT-Discipline | 025 | Process |
| PMT-Discipline | 400 | Procurement |
| PMT-Doc. Type | DEV | Develop Dwgs/Spec/RFQ |
| PMT-Phase | C | Construction |
| PMT-Phase | E | Engineering |
| PMT-Phase | P | Procurement |
| PMT-Phase | S | Precomm/Commissioning |
| PMT-Respons. | CiC | General Civil Contractor |
| PMT-Respons. | FoW | Contractor Foundation Works |
| PMT-Respons. | LND | LINDE |
| PMT-Respons. | MO01 | Mostostroy Piling Contract Downstream (25.09.09) |
| PMT-Respons. | MO02 | Mostostroy Piling Contract Upstream (12.02.10) |
| PMT-Respons. | MO03 | Mostostroy Foundation Contract 1st Part (23.04.10) |
| PMT-Respons. | MO04 | Mostostroy Civil Contract 1st Part (Site Facilities/Precast 21.07.10) |
| PMT-Respons. | OWN | Sibur/Tobolsk Polymer |
| PMT-Respons. | PMT | Sibur/Fluor |
| PMT-Respons. | UIO | Utilities Infrastructure and Offsites |
| PMT-Schedule Org | 001 | Major Milestones |
| PMT-Schedule Org | 200 | Polypropylene Unit (PP) |
| Pro Unit/DocCode | 90 | Activities for Product Handling |
| Pro Unit/DocCode | 91 | Activities for PP Process Plant |
| Russia Construction Area | 00 | Строительство - Общее |
| Russia Construction Area | 0C | Сроки строительства по дисциплинам |
| Russia Construction Area | 10 | CA10 - Участок мембранной установки извлечения пропилена |
| Russia Construction Area | 11 | CA11 - Линии сжатия отходящего газа 1 + 2 |
| Russia Construction Area | 12 | CA12 - Линия 1 полимеризации |
| Russia Construction Area | 13 | CA13 - Линия 2 полимеризации |
| Russia Construction Area | 14 | CA14 - Участок факельной установки |
| Russia Construction Area | 15 | CA15 - Буферная емкость воздуха КИП |
| Russia Construction Area | 16 | CA16 - Подстанция / RIE |
| Russia Construction Area | 17 | CA17 - Экструдер / Операции с аддитивами - Линия 1/2 |
| Russia Construction Area | 31 | CA31 - Здание хранения/упаковки и отгрузки |
| Russia Construction Area | 41 | CA41 - Операторная |
| Russia Construction Area | 51 | CA51 - Трубные эстакады (между CA11-15/17/19/52/53/54) |
| Russia Construction Area | 52 | CA52 - Трубные эстакады (между CA11/51) |
| Russia Construction Area | 53 | CA53 - Трубные эстакады (между CA14/51) |
| Russia Construction Area | 54 | CA54 - Трубные эстакады (между CA15/16/51/55) |
| Russia Construction Area | 55 | CA55 - Трубные эстакады (между CA16/17/56) |
| Russia Construction Area | 56 | CA56 - Трубные эстакады (между CA17/31/55) |
| Russia WBS Discipline (Russia) | 0 | Дисциплины - Общее |
| Russia WBS Discipline (Russia) | B | Механическое оборудование ї Стационарное |
| Russia WBS Discipline (Russia) | C | Общестроительная часть |
| Russia WBS Discipline (Russia) | E | Электрооборудование |
| Russia WBS Discipline (Russia) | H | ОВКВ |
| Russia WBS Discipline (Russia) | J | КИП |
| Russia WBS Discipline (Russia) | M | Механическое оборудование ї Вращающееся |
| Russia WBS Discipline (Russia) | N | Стальные конструкции |
| Russia WBS Discipline (Russia) | R | Трубопроводы |
| Russia WBS Discipline (Russia) | S | Безопасность и охрана окружающей среды |
| Russia WBS Discipline (Russia) | V | Изоляция |
| Russia WBS Discipline (Russia) | W | Окраска |
| Russia WBS Objects | 0000 | Общее - все CA |
| Russia WBS Objects | 0C00 | Сроки строительства по дисциплинам |
| Russia WBS Objects | 1000 | Общее - CA10 |
| Russia WBS Objects | 1010 | Участок мембранной установки извлечения пропилена - CA10 |
| Russia WBS Objects | 1100 | Общее - CA11 |
| Russia WBS Objects | 1110 | Здание компрессора отходящего газа - CA11 |
| Russia WBS Objects | 1111 | Секция фильтра компрессора отходящего газа - CA11 |
| Russia WBS Objects | 1200 | Общее - CA12 |
| Russia WBS Objects | 1201 | Конструкция реактора - CA12 |
| Russia WBS Objects | 1204 | Соединительные конструкции между реактором и зданием ТЭА - CA12 |
| Russia WBS Objects | 1205 | Устройство для демонтажа мешалки - CA12 |
| Russia WBS Objects | 1221 | Здание катализатора, линия 1 - CA12 |
| Russia WBS Objects | 1222 | Здание ТЭА, линия 1 - CA12 |
| Russia WBS Objects | 1230 | Прочее оборудование на нулевой отметке - CA12 |
| Russia WBS Objects | 1232 | Компрессор рециркулирующего газа - CA12 |
| Russia WBS Objects | 1233 | Дожимной компрессор газовых сдувок - CA12 |
| Russia WBS Objects | 1300 | Общее - CA13 |
| Russia WBS Objects | 1301 | Конструкция реактора - CA13 |
| Russia WBS Objects | 1303 | Соединительные конструкции здания экструдера - CA13 |
| Russia WBS Objects | 1304 | Соединительные конструкции между реактором и зданием ТЭА - CA13 |
| Russia WBS Objects | 1305 | Устройство для демонтажа мешалки - CA13 |
| Russia WBS Objects | 1321 | Здание катализатора, линия 2 - CA13 |
| Russia WBS Objects | 1322 | Здание ТЭА, линия 2 - CA13 |
| Russia WBS Objects | 1330 | Прочее оборудование на нулевой отметке - CA13 |
| Russia WBS Objects | 1332 | Компрессор рециркулирующего газа - CA13 |
| Russia WBS Objects | 1400 | Общее - CA14 |
| Russia WBS Objects | 1410 | Комплектная факельная установка - CA14 |
| Russia WBS Objects | 1420 | Секция сепаратора факела - CA14 |
| Russia WBS Objects | 1500 | Общее - CA15 |
| Russia WBS Objects | 1510 | Секция буферной емкости воздуха - CA15 |
| Russia WBS Objects | 1600 | Общее - CA16 |
| Russia WBS Objects | 1610 | Подстанция / RIE - CA16 |
| Russia WBS Objects | 1700 | Общее - CA17 |
| Russia WBS Objects | 1704 | Внутренние трубные эстакады/платформы - CA17 |
| Russia WBS Objects | 1707 | Соединительная трубная эстакада - CA17 и CA12 |
| Russia WBS Objects | 1708 | Соединительная трубная эстакада - CA17 и CA13 |
| Russia WBS Objects | 1710 | Здание экструзии, 2-й этаж +0,15 м - CA17 |
| Russia WBS Objects | 1718 | Здание экструзии, 3-й этаж +12,50 м - CA17 |
| Russia WBS Objects | 1720 | Здание экструзии, 4-й этаж +18,50 м - CA17 |
| Russia WBS Objects | 1730 | Здание экструзии, 5-й этаж +24,50 м - CA17 |
| Russia WBS Objects | 1736 | Здание экструзии, 6-й этаж +30,50 м - CA17 |
| Russia WBS Objects | 1740 | Здание экструзии, 7-й этаж +36,50 м - CA17 |
| Russia WBS Objects | 1760 | Конструкция бункера продувки +94 м - CA17 |
| Russia WBS Objects | 1770 | Вестибюль, южная сторона - CA17 |
| Russia WBS Objects | 3100 | Общее - CA31 |
| Russia WBS Objects | 3110 | Конструкция силоса - CA31 |
| Russia WBS Objects | 3120 | Помещения нагнетателей и загрузки автотранспорта - CA31 |
| Russia WBS Objects | 3130 | Офисное здание и трансформаторная - CA31 |
| Russia WBS Objects | 3140 | Участок подготовки и отгрузки продукта - CA31 |
| Russia WBS Objects | 4100 | Общее - CA41 |
| Russia WBS Objects | 5100 | Общее - CA51 |
| Russia WBS Objects | 5101 | Трубная эстакада 1 - часть 1 - CA51 |
| Russia WBS Objects | 5102 | Трубная эстакада 1 - часть 2 - CA51 |
| Russia WBS Objects | 5103 | Трубная эстакада 1 - часть 3 - CA51 |
| Russia WBS Objects | 5104 | Трубная эстакада 1 - часть 4 - CA51 |
| Russia WBS Objects | 5200 | Общее - CA52 |
| Russia WBS Objects | 5201 | Трубная эстакада 2 - CA52 |
| Russia WBS Objects | 5301 | Трубная эстакада 3 - CA53 |
| Russia WBS Objects | 5400 | Общее - CA54 |
| Russia WBS Objects | 5401 | Трубная эстакада 4 - часть 1 - CA54 |
| Russia WBS Objects | 5402 | Трубная эстакада 4 - часть 2 - CA54 |
| Russia WBS Objects | 5500 | Общее - CA55 |
| Russia WBS Objects | 5501 | Трубная эстакада 5 - часть 1 - CA55 |
| Russia WBS Objects | 5502 | Трубная эстакада 5 - часть 2 - CA55 |
| Russia WBS Objects | 5503 | Трубная эстакада 5 - часть 3 - CA55 |
| Russia WBS Objects | 5600 | Общее - CA56 |
| Russia WBS Objects | 5601 | Трубная эстакада 6 - CA56 |
| Russia WBS Objects | 96 | Concrete Paving - CA96 |
| Russia WBS Phase | X | Строительство |
| Subcontractor | ChSK | Steel Structure |
| Subcontractor | KRILAK | Fire Profing |
| Subcontractor | MO11 | Civil |
| Subcontractor | OMUS-1 | Steel/ Mechanical works |
| Subcontractor | SEM | Mechanical works |
| Subcontractor | SM | Steel Structure |
| Subcontractor | URMA | Electrical & Instrumentation |
| Subcontractor | VNZM | Mechanical works |
| Type of Work | ALL4 | Silos & Blenders |
| Type of Work | C02 | Civil Subcontract General |
| Type of Work | D01 | General Cargo Subcontract |
| Type of Work | E01A | MV-SWG / MCC |
| Type of Work | J06 | DCS / SIS |
| Type of Work | PU10 | Conveying System |
| Type of Work | XBB | Equipment Installation |
| Type of Work | XNK | Steel Structure for Equipment |
| UPT | IMS | Integrated Management Schedule |
| UPT | LND | Linde |
| UPT | OWN | Owner |
| WBS Discipline | 0B | General Activities |
| WBS Discipline | B | Mechanical - Stationary Equipment |
| WBS Discipline | C | Civil |
| WBS Discipline | E | Electrical |
| WBS Discipline | H | HVAC |
| WBS Discipline | I | Ineos Activities |
| WBS Discipline | J | Instrumentation |
| WBS Discipline | M | Mechanical - Rotating Equipment |
| WBS Discipline | N | Structural Steel |
| WBS Discipline | R | Piping |
| WBS Discipline | S | Safety & Environment |
| WBS Discipline | U | Package Units |
| WBS Discipline | V | Insulation |
| WBS Discipline | W | Painting |
| WBS Discipline | Y | Precommissioning |
| WBS Objects | 0000 | Generals - all CA's |
| WBS Objects | 0C00 | Construction Milestones Disciplines |
| WBS Objects | 1000 | Generals CA10 |
| WBS Objects | 1010 | Propylene Recovery Unit Area - CA10 |
| WBS Objects | 1100 | Generals CA11 |
| WBS Objects | 1110 | Offgas Compressor Building - CA11 |
| WBS Objects | 1111 | Offgas Compressor Filter Section - CA11 |
| WBS Objects | 1200 | Generals - CA12 |
| WBS Objects | 1201 | Reactor Structure - CA12 |
| WBS Objects | 1204 | Connection Structure Reactor to Teal Bldg - CA12 |
| WBS Objects | 1205 | Agitator Removable Unit - CA12 |
| WBS Objects | 1221 | Catalyst Building Line 1 - CA12 |
| WBS Objects | 1222 | Teal Building Line 1 - CA12 |
| WBS Objects | 1230 | Other Ground Based Eqpt - CA12 |
| WBS Objects | 1232 | Recycle Gas Compressor - CA12 |
| WBS Objects | 1233 | Bleed Booster Compressor - CA12 |
| WBS Objects | 1300 | Generals - CA13 |
| WBS Objects | 1301 | Reactor Structure - CA13 |
| WBS Objects | 1303 | Connection Structure to Extruder Bldg. - CA13 |
| WBS Objects | 1304 | Connection Structure Reactor to Teal Bldg - CA13 |
| WBS Objects | 1305 | Agitator Removable Unit - CA13 |
| WBS Objects | 1321 | Catalyst Building Line 2 - CA13 |
| WBS Objects | 1322 | Teal Building Line 2 - CA13 |
| WBS Objects | 1330 | Other Ground Based Eqpt - CA13 |
| WBS Objects | 1332 | Recycle Gas Compressor - CA13 |
| WBS Objects | 1400 | Generals - CA14 |
| WBS Objects | 1410 | Flare Package - CA14 |
| WBS Objects | 1420 | Flare Knockout Drum Section - CA14 |
| WBS Objects | 1500 | Generals - CA15 |
| WBS Objects | 1510 | Air Buffer Vessel Section - CA15 |
| WBS Objects | 1600 | Generals - CA16 |
| WBS Objects | 1610 | Substation / RIE's - CA16 |
| WBS Objects | 1700 | Generals - CA17 |
| WBS Objects | 1704 | Internal Pipe Racks - CA17 |
| WBS Objects | 1707 | Connection Piperack - CA17 to CA12 |
| WBS Objects | 1708 | Connection Piperack - CA17 to CA13 |
| WBS Objects | 1710 | Extrusion Bldg 1st Floor +98,650m (+0,15m) - CA17 |
| WBS Objects | 1711 | Extrusion Structure |
| WBS Objects | 1718 | Extrusion Bldg 2nd Floor +111,250m (+12,75m) - CA17 |
| WBS Objects | 1720 | Extrusion Bldg 3rd Floor +117,550m (+19,05m) - CA17 |
| WBS Objects | 1730 | Extrusion Bldg 4th Floor +123,850m (+25,35m) - CA17 |
| WBS Objects | 1736 | Extrusion Bldg 5th Floor +130,150m (+31,65m) - CA17 |
| WBS Objects | 1740 | Extrusion Bldg 6th Floor +136,450m (+37,95m) - CA17 |
| WBS Objects | 1760 | Purge Bin Structure +189,245m (+90,75m) - CA17 |
| WBS Objects | 1770 | Entrance Hall southside - CA17 |
| WBS Objects | 1810 | Central Chiller Unit Area - CA18 |
| WBS Objects | 3100 | Generals - CA31 |
| WBS Objects | 3110 | Silo Structure - CA31 |
| WBS Objects | 3120 | Blower Room & Truck Inliner Loading - CA31 |
| WBS Objects | 3130 | Service Area - CA31 |
| WBS Objects | 3140 | Warehouse - CA31 |
| WBS Objects | 4100 | Generals - CA41 |
| WBS Objects | 5100 | Generals - CA51 |
| WBS Objects | 5101 | Pipe Rack 1 - Part 1 - CA51 |
| WBS Objects | 5102 | Pipe Rack 1 - Part 2 - CA51 |
| WBS Objects | 5103 | Pipe Rack 1 - Part 3 - CA51 |
| WBS Objects | 5104 | Pipe Rack 1 - Part 4 - CA51 |
| WBS Objects | 5200 | Generals - CA52 |
| WBS Objects | 5201 | Pipe Rack 2 - CA52 |
| WBS Objects | 5300 | Generals - CA53 |
| WBS Objects | 5301 | Pipe Rack 3 - CA53 |
| WBS Objects | 5400 | Generals - CA54 |
| WBS Objects | 5401 | Pipe Rack 4 - Part 1 - CA54 |
| WBS Objects | 5402 | Pipe Rack 4 - Part 2 - CA54 |
| WBS Objects | 5500 | Generals - CA55 |
| WBS Objects | 5501 | Pipe Rack 5 - Part 1 - CA55 |
| WBS Objects | 5502 | Pipe Rack 5 - Part 2 - CA55 |
| WBS Objects | 5503 | Pipe Rack 5 - Part 3 - CA55 |
| WBS Objects | 5600 | Generals - CA56 |
| WBS Objects | 5601 | Pipe Rack 6 - CA56 |
| WBS Objects | 9600 | Concrete Paving - CA96 |
| WBS Objects | LUTZ | Construction General |
| WBS Phase | S | Start-Up |
| WBS Phase | X | Construction |
| WBS Phase | Y | Precommissioning |
| WBS Phase | Z | Commissioning |
| WBS Type of Work | 0000 | Engineering - General |
| WBS Type of Work | X000 | Construction Milestones - Disciplines |
| WBS Type of Work | X010 | Construction Milestones - Mechanical Completion |
| WBS Type of Work | X020 | Construction Milestones - Phases |
| WBS Type of Work | X030 | Construction Milestones - Utility Needs |
| WBS Type of Work | XB00 | Installation Static Eqpt - General |
| WBS Type of Work | XB10 | Installation Static Eqpt - Vessel / Drums |
| WBS Type of Work | XB30 | Installation Static Eqpt - Reactors |
| WBS Type of Work | XB60 | Installation Static Eqpt - Silos |
| WBS Type of Work | XB90 | Installation Static Eqpt - Misc |
| WBS Type of Work | XC00 | Civil Works - Conctruction General |
| WBS Type of Work | XC11 | Civil Works - Exavation |
| WBS Type of Work | XC15 | Civil Works - Piling |
| WBS Type of Work | XC19 | Civil Works - Backfill |
| WBS Type of Work | XC20 | Civil Works - Concrete Works Foundations |
| WBS Type of Work | XC30 | Civil Works - Underground Installation |
| WBS Type of Work | XC40 | Civil Works - Concrete Works Bldgs & Structures |
| WBS Type of Work | XC50 | Civil Works - Finishing Works Building |
| WBS Type of Work | XC52 | Civil Works - False Floor |
| WBS Type of Work | XC60 | Civil Works - Paving |
| WBS Type of Work | XC80 | Civil Works - Fire Proofing |
| WBS Type of Work | XE00 | Elec Installation - General |
| WBS Type of Work | XE20 | Elec Installation - Transformer/Switchgears/MCCs |
| WBS Type of Work | XE34 | Elec Installation - Local Operation Panels |
| WBS Type of Work | XE40 | Elec Installation - Cable Trays/Conduits |
| WBS Type of Work | XE41 | Elec Installation - Cable Trays Substation |
| WBS Type of Work | XE50 | Elec Installation - Cable Pulling General |
| WBS Type of Work | XE60 | Elec Installation - Termination & Testing |
| WBS Type of Work | XE70 | Elec Installation - Lighting & Small Power |
| WBS Type of Work | XE80 | Elec Installation - Heat Tracing |
| WBS Type of Work | XE91 | Elec Installation - Grounding & Lightning |
| WBS Type of Work | XE92 | Elec Installation - Fire Detection System |
| WBS Type of Work | XE96 | Elec Installation - Communication System |
| WBS Type of Work | XH00 | HVAC Installation - General |
| WBS Type of Work | XH20 | HVAC Installation - Testing&Commissioning |
| WBS Type of Work | XJ00 | Instr Installation - General |
| WBS Type of Work | XJ20 | Instr Installation - PLS / Cabinets |
| WBS Type of Work | XJ30 | Instr Installation - Field Equipment |
| WBS Type of Work | XJ32 | Instr Installation - Junction Boxes |
| WBS Type of Work | XJ38 | Instr Installation - Analyser Equipment |
| WBS Type of Work | XJ39 | Instr Installation - Earthing |
| WBS Type of Work | XJ40 | Instr Installation - Cable Trays/Conduits |
| WBS Type of Work | XJ41 | Instr Installation - Cable Trays False Floor |
| WBS Type of Work | XJ42 | Instr Installation - Cable Trays to JB |
| WBS Type of Work | XJ44 | Instr Installation - Cable Trays to Intruments |
| WBS Type of Work | XJ51 | Instr Installation - Cable Pulling RIE internal |
| WBS Type of Work | XJ52 | Instr Installation - Cable Pulling to JB |
| WBS Type of Work | XJ54 | Instr Installation - Cable Pulling to Instrument |
| WBS Type of Work | XJ61 | Instr Installation - Termination RIE's internal |
| WBS Type of Work | XJ62 | Instr Installation - Termination RIE to JBs |
| WBS Type of Work | XJ64 | Instr Installation - Termination JB's to Instrum |
| WBS Type of Work | XJ70 | Instr Installation - Instrument Tubing |
| WBS Type of Work | XJ80 | Instr Installation - Loop Checks |
| WBS Type of Work | XM00 | Installation Rot Eqpt - General |
| WBS Type of Work | XM10 | Installation Rot Eqpt - Compressors General |
| WBS Type of Work | XM20 | Installation Rot Eqpt - Pumps General |
| WBS Type of Work | XN00 | Steel Struc Erection - General |
| WBS Type of Work | XN05 | Steel Struc Erection - KMD Erection Drawings |
| WBS Type of Work | XN06 | Steel Struc Erection - Steel Delivery Date (Finish) |
| WBS Type of Work | XN20 | Steel Struc Erection - Primary Steel |
| WBS Type of Work | XN30 | Steel Struc Erection - Platforms |
| WBS Type of Work | XN40 | Steel Struc Erection - Railings, Ladders, etc. |
| WBS Type of Work | XN60 | Steel Struc Erection - Gratings |
| WBS Type of Work | XN70 | Steel Struc Erection - Supports (Piping / E&I) |
| WBS Type of Work | XN80 | Steel Struc Erection - Cladding |
| WBS Type of Work | XR20 | Piping - Prefabrication |
| WBS Type of Work | XR40 | Piping - Installation |
| WBS Type of Work | XR60 | Piping - Pressure Tests |
| WBS Type of Work | XR80 | Piping - Reinstatement |
| WBS Type of Work | XS40 | Safety - Installation Noise Protection |
| WBS Type of Work | XV00 | Insulation - General |
| WBS Type of Work | XV30 | Insulation - Equipment |
| WBS Type of Work | XV50 | Insulation - Piping |
| WBS Type of Work | XW00 | Coating - General |
| WBS Type of Work | XW50 | Coating - Piping |
| WBS Type of Work | YY10 | Ineos Activities (Pre-/Commissioning) |
| Zeigen/n. Zeigen | 0 | nicht zeigen |
| Zeigen/n. Zeigen | C2 | CA16 Substation |
| Zeigen/n. Zeigen | C4 | Critical Path - PRU |
| Zeigen/n. Zeigen | C5 | Critical Path - UG Piping |
| Zeigen/n. Zeigen | C6 | Fire-/ Gas Detection System |
| Zeigen/n. Zeigen | C7 | CA31 Storage / Packaging and Shipping Building |
| Zeigen/n. Zeigen | C8 | Heavy Lift Reactors |
| Zeigen/n. Zeigen | C9 | CA17 Extrusion Building |
| Zeigen/n. Zeigen | C9-1 | CA17 Extrusion Building |
| Zeigen/n. Zeigen | D | for discussion |
| Zeigen/n. Zeigen | EQ | Equipment, itemized |
| Zeigen/n. Zeigen | FL | Flare Package |
| Zeigen/n. Zeigen | KMD | KMD-Assy Drawing |
| Zeigen/n. Zeigen | L2 | Level 2 PMT |
| Zeigen/n. Zeigen | L4 | Level 4 |
| Zeigen/n. Zeigen | M1 | Milestones Level 1 Schedule |
| Zeigen/n. Zeigen | SD | Steel Delivery Date |
