# Tobolsk-A3JI-PP-Plant 500 kt/a Construction L3_ URMA - Sended 20110805

Schedule from Primavera P6, 2012-02-20 to 2012-08-29, data date 2011-06-25.

## Calendars

- TB26 - 3 - Construct-normal *: Mon-Sat 08:00-12:00, 13:00-17:00; Sun off. Exceptions (off unless hours are given): 2012-02-23, 2012-03-08, 2012-05-01, 2012-05-09, 2012-06-12.
- TB26 - 3 - Construction Normal 7days * CA17: Mon 08:00-16:00; Tue-Sun 08:00-12:00, 13:00-17:00. Exceptions (off unless hours are given): 2012-02-23, 2012-03-08, 2012-05-01, 2012-05-09, 2012-06-12.

## Schedule

| WBS | Activity | Start | Finish |
| --- | --- | --- | --- |
| 1 | **PROJECT A3JI** | 2012-02-20 | 2012-08-29 |
| PP | **Area PP** | 2012-02-20 | 2012-08-29 |
| X | **Construction** | 2012-02-20 | 2012-08-29 |
| 0B | **General Activities** |  |  |
| C | **Civil Work** |  |  |
| N | **Structural Steel** |  |  |
| H | **HVAC** |  |  |
| U | **Package Units** |  |  |
| B | **Mechanical - Stationary Equipment** |  |  |
| M | **Mechanical - Rotating Equipment** |  |  |
| R | **Piping** |  |  |
| E | **Electrical** |  |  |
| J | **Instrumentation** |  |  |
| S | **Safety & Environment** |  |  |
| W | **Painting** |  |  |
| V | **Insulation** |  |  |
| 00 | **Milestones Construction** |  |  |
| 0B | **General Activities** |  |  |
| C | **Civil Work** |  |  |
| N | **Structural Steel** |  |  |
| H | **HVAC** |  |  |
| U | **Package Units** |  |  |
| B | **Mechanical - Stationary Equipment** |  |  |
| M | **Mechanical - Rotating Equipment** |  |  |
| R | **Piping** |  |  |
| E | **Electrical** |  |  |
| J | **Instrumentation** |  |  |
| S | **Safety & Environment** |  |  |
| W | **Painting** |  |  |
| V | **Insulation** |  |  |
| 10 | **CA10 - Propylene Recovery Section** |  |  |
| 00 | **CA10 - General** |  |  |
| 10 | **CA10 - Propylene Recovery Unit Area** |  |  |
| C | **Civil Work** |  |  |
| N | **Structural Steel** |  |  |
| H | **HVAC** |  |  |
| U | **Package Units** |  |  |
| B | **Mechanical - Stationary Equipment** |  |  |
| M | **Mechanical - Rotating Equipment** |  |  |
| R | **Piping** |  |  |
| E | **Electrical** |  |  |
| J | **Instrumentation** |  |  |
| S | **Safety & Environment** |  |  |
| W | **Painting** |  |  |
| V | **Insulation** |  |  |
| 11 | **CA11 - Offgas Compression Line 1+2** |  |  |
| 00 | **CA11 - General** |  |  |
| 0B | **General Activities** |  |  |
| C | **Civil Work** |  |  |
| 04 | **CA11 - Structures inside Offgas Compr Bldg** |  |  |
| 10 | **CA11 - Offgas Compressor Building** |  |  |
| C | **Civil Work** |  |  |
| N | **Structural Steel** |  |  |
| H | **HVAC** |  |  |
| U | **Package Units** |  |  |
| B | **Mechanical - Stationary Equipment** |  |  |
| M | **Mechanical - Rotating Equipment** |  |  |
| R | **Piping** |  |  |
| E | **Electrical** |  |  |
| J | **Instrumentation** |  |  |
| S | **Safety & Environment** |  |  |
| W | **Painting** |  |  |
| V | **Insulation** |  |  |
| 11 | **CA11 - Offgas Compressor Filter Section** |  |  |
| C | **Civil Work** |  |  |
| N | **Structural Steel** |  |  |
| H | **HVAC** |  |  |
| U | **Package Units** |  |  |
| B | **Mechanical - Stationary Equipment** |  |  |
| M | **Mechanical - Rotating Equipment** |  |  |

| WBS | Activity |
| --- | --- |
| R | **Piping** |
| E | **Electrical** |
| J | **Instrumentation** |
| S | **Safety & Environment** |
| W | **Painting** |
| V | **Insulation** |
| 20 | **CA11 - Propylen Recovery Section** |
| C | **Civil Work** |
| N | **Structural Steel** |
| H | **HVAC** |
| U | **Package Units** |
| B | **Mechanical - Stationary Equipment** |
| M | **Mechanical - Rotating Equipment** |
| R | **Piping** |
| E | **Electrical** |
| J | **Instrumentation** |
| S | **Safety & Environment** |
| W | **Painting** |
| V | **Insulation** |
| 30 | **CA11 - Flare Knockout Drum Section** |
| 12 | **CA12 - Polymerisation Line 1** |
| 00 | **CA12 - General** |
| 0B | **General Activities** |
| C | **Civil Work** |
| E | **Electrical** |
| 01 | **CA12 - Reactor Structure** |
| C | **Civil Work** |
| N | **Structural Steel** |
| H | **HVAC** |
| U | **Package Units** |
| B | **Mechanical - Stationary Equipment** |
| M | **Mechanical - Rotating Equipment** |
| R | **Piping** |
| E | **Electrical** |
| J | **Instrumentation** |
| S | **Safety & Environment** |
| W | **Painting** |
| V | **Insulation** |
| 02 | **CA12 - Teal Bldg Steel Structure** |
| C | **Civil Work** |
| N | **Structural Steel** |
| H | **HVAC** |
| U | **Package Units** |
| B | **Mechanical - Stationary Equipment** |
| M | **Mechanical - Rotating Equipment** |
| R | **Piping** |
| E | **Electrical** |
| J | **Instrumentation** |
| S | **Safety & Environment** |
| W | **Painting** |
| V | **Insulation** |
| 03 | **CA12 - Connection Structure to Extruder Bldg.** |
| C | **Civil Work** |
| N | **Structural Steel** |
| H | **HVAC** |
| U | **Package Units** |
| B | **Mechanical - Stationary Equipment** |
| M | **Mechanical - Rotating Equipment** |
| R | **Piping** |
| E | **Electrical** |
| J | **Instrumentation** |
| S | **Safety & Environment** |
| W | **Painting** |
| V | **Insulation** |
| 04 | **CA12 - Connection Structure Reactor to Teal Bldg** |
| C | **Civil Work** |
| N | **Structural Steel** |
| H | **HVAC** |
| U | **Package Units** |
| B | **Mechanical - Stationary Equipment** |

| WBS | Activity |
| --- | --- |
| M | **Mechanical - Rotating Equipment** |
| R | **Piping** |
| E | **Electrical** |
| J | **Instrumentation** |
| S | **Safety & Environment** |
| W | **Painting** |
| V | **Insulation** |
| 05 | **CA12 - Agitator Removable Unit** |
| C | **Civil Work** |
| N | **Structural Steel** |
| H | **HVAC** |
| U | **Package Units** |
| B | **Mechanical - Stationary Equipment** |
| M | **Mechanical - Rotating Equipment** |
| R | **Piping** |
| E | **Electrical** |
| J | **Instrumentation** |
| S | **Safety & Environment** |
| W | **Painting** |
| V | **Insulation** |
| 21 | **CA12 - Catalyst Building Line 1** |
| C | **Civil Work** |
| N | **Structural Steel** |
| H | **HVAC** |
| U | **Package Units** |
| B | **Mechanical - Stationary Equipment** |
| M | **Mechanical - Rotating Equipment** |
| R | **Piping** |
| E | **Electrical** |
| J | **Instrumentation** |
| S | **Safety & Environment** |
| W | **Painting** |
| V | **Insulation** |
| 22 | **CA12 - Teal Building Line 1** |
| C | **Civil Work** |
| N | **Structural Steel** |
| H | **HVAC** |
| U | **Package Units** |
| B | **Mechanical - Stationary Equipment** |
| M | **Mechanical - Rotating Equipment** |
| R | **Piping** |
| E | **Electrical** |
| J | **Instrumentation** |
| S | **Safety & Environment** |
| W | **Painting** |
| V | **Insulation** |
| 30 | **CA12 - Other Ground Based Eqpt** |
| C | **Civil Work** |
| M | **Mechanical - Rotating Equipment** |
| B | **Mechanical - Stationary Equipment** |
| R | **Piping** |
| E | **Electrical** |
| J | **Instrumentation** |
| W | **Painting** |
| V | **Insulation** |
| 31 | **CA12 - Reactor** |
| 32 | **CA12 - Recycle Gas Compressor** |
| C | **Civil Work** |
| M | **Mechanical - Rotating Equipment** |
| B | **Mechanical - Stationary Equipment** |
| R | **Piping** |
| E | **Electrical** |
| J | **Instrumentation** |
| W | **Painting** |
| V | **Insulation** |
| 33 | **CA12 - Bleed Booster Compressor** |
| C | **Civil Work** |
| M | **Mechanical - Rotating Equipment** |
| B | **Mechanical - Stationary Equipment** |
| R | **Piping** |

| WBS | Activity |
| --- | --- |
| E | **Electrical** |
| J | **Instrumentation** |
| W | **Painting** |
| V | **Insulation** |
| 13 | **CA13 - Polymerisation Line 2** |
| 00 | **CA13 - General** |
| 0B | **General Activities** |
| C | **Civil Work** |
| E | **Electrical** |
| 01 | **CA13 - Reactor Structure** |
| C | **Civil Work** |
| N | **Structural Steel** |
| H | **HVAC** |
| U | **Package Units** |
| B | **Mechanical - Stationary Equipment** |
| M | **Mechanical - Rotating Equipment** |
| R | **Piping** |
| E | **Electrical** |
| J | **Instrumentation** |
| S | **Safety & Environment** |
| W | **Painting** |
| V | **Insulation** |
| 02 | **CA13 - Teal Bldg Steel Structure** |
| 03 | **CA13 - Connection Structure to Extruder Bldg.** |
| C | **Civil Work** |
| N | **Structural Steel** |
| H | **HVAC** |
| U | **Package Units** |
| B | **Mechanical - Stationary Equipment** |
| M | **Mechanical - Rotating Equipment** |
| R | **Piping** |
| E | **Electrical** |
| J | **Instrumentation** |
| S | **Safety & Environment** |
| W | **Painting** |
| V | **Insulation** |
| 04 | **CA13 - Connection Structure Reactor to Teal Bldg** |
| C | **Civil Work** |
| N | **Structural Steel** |
| H | **HVAC** |
| U | **Package Units** |
| B | **Mechanical - Stationary Equipment** |
| M | **Mechanical - Rotating Equipment** |
| R | **Piping** |
| E | **Electrical** |
| J | **Instrumentation** |
| S | **Safety & Environment** |
| W | **Painting** |
| V | **Insulation** |
| 05 | **CA13 - Agitator Removable Unit** |
| C | **Civil Work** |
| N | **Structural Steel** |
| H | **HVAC** |
| U | **Package Units** |
| B | **Mechanical - Stationary Equipment** |
| M | **Mechanical - Rotating Equipment** |
| R | **Piping** |
| E | **Electrical** |
| J | **Instrumentation** |
| S | **Safety & Environment** |
| W | **Painting** |
| V | **Insulation** |
| 21 | **CA13 - Catalyst Building Line 2** |
| C | **Civil Work** |
| N | **Structural Steel** |
| H | **HVAC** |
| U | **Package Units** |
| B | **Mechanical - Stationary Equipment** |
| M | **Mechanical - Rotating Equipment** |
| R | **Piping** |

| WBS | Activity |
| --- | --- |
| E | **Electrical** |
| J | **Instrumentation** |
| S | **Safety & Environment** |
| W | **Painting** |
| V | **Insulation** |
| 22 | **CA13 - Teal Building Line 2** |
| C | **Civil Work** |
| N | **Structural Steel** |
| H | **HVAC** |
| U | **Package Units** |
| B | **Mechanical - Stationary Equipment** |
| M | **Mechanical - Rotating Equipment** |
| R | **Piping** |
| E | **Electrical** |
| J | **Instrumentation** |
| S | **Safety & Environment** |
| W | **Painting** |
| V | **Insulation** |
| 30 | **CA13 - Other Ground Based Eqpt** |
| C | **Civil Work** |
| B | **Mechanical - Stationary Equipment** |
| M | **Mechanical - Rotating Equipment** |
| E | **Electrical** |
| R | **Piping** |
| J | **Instrumentation** |
| W | **Painting** |
| V | **Insulation** |
| 31 | **CA13 - Reactor** |
| 32 | **CA13 - Recycle Gas Compressor** |
| C | **Civil Work** |
| B | **Mechanical - Stationary Equipment** |
| M | **Mechanical - Rotating Equipment** |
| R | **Piping** |
| E | **Electrical** |
| J | **Instrumentation** |
| W | **Painting** |
| V | **Insulation** |
| 33 | **CA13 - Bleed Booster Compressor** |
| 14 | **CA14 - Flare** |
| 00 | **CA14 - General** |
| 0B | **General Activities** |
| 04 | **CA14 - Auxiliary Structures** |
| 10 | **CA14 - Flare Package** |
| 0B | **General Activities** |
| C | **Civil Work** |
| N | **Structural Steel** |
| H | **HVAC** |
| U | **Package Units** |
| B | **Mechanical - Stationary Equipment** |
| M | **Mechanical - Rotating Equipment** |
| R | **Piping** |
| E | **Electrical** |
| J | **Instrumentation** |
| S | **Safety & Environment** |
| W | **Painting** |
| V | **Insulation** |
| 20 | **CA14 - Flare Knockout Drum Section** |
| C | **Civil Work** |
| N | **Structural Steel** |
| H | **HVAC** |
| U | **Package Units** |
| B | **Mechanical - Stationary Equipment** |
| M | **Mechanical - Rotating Equipment** |
| R | **Piping** |
| E | **Electrical** |
| J | **Instrumentation** |
| S | **Safety & Environment** |
| W | **Painting** |
| V | **Insulation** |
| 15 | **CA15 - Instrument Air / Lifting Stations** |

| WBS | Activity | Start | Finish |
| --- | --- | --- | --- |
| 00 | **CA15 - General** |  |  |
| 0B | **General Activities** |  |  |
| C | **Civil Work** |  |  |
| 01 | **CA15 - Air Buffer Vessel Platform** |  |  |
| 04 | **CA15 - Auxiliary Structures** |  |  |
| 10 | **CA15 - Air Buffer Vessel Section** |  |  |
| C | **Civil Work** |  |  |
| N | **Structural Steel** |  |  |
| H | **HVAC** |  |  |
| U | **Package Units** |  |  |
| B | **Mechanical - Stationary Equipment** |  |  |
| M | **Mechanical - Rotating Equipment** |  |  |
| R | **Piping** |  |  |
| E | **Electrical** |  |  |
| J | **Instrumentation** |  |  |
| S | **Safety & Environment** |  |  |
| W | **Painting** |  |  |
| V | **Insulation** |  |  |
| 11 | **CA15 - Sanitary Lifting Station Section** |  |  |
| 16 | **CA16 - Substation** |  |  |
| 00 | **CA16 - General** |  |  |
| 0B | **General Activities** |  |  |
| 04 | **CA16 - Auxiliary Structures** |  |  |
| 10 | **CA16 - Substation / RIE's** |  |  |
| C | **Civil Work** |  |  |
| N | **Structural Steel** |  |  |
| H | **HVAC** |  |  |
| U | **Package Units** |  |  |
| B | **Mechanical - Stationary Equipment** |  |  |
| M | **Mechanical - Rotating Equipment** |  |  |
| R | **Piping** |  |  |
| E | **Electrical** |  |  |
| J | **Instrumentation** |  |  |
| S | **Safety & Environment** |  |  |
| W | **Painting** |  |  |
| V | **Insulation** |  |  |
| 17 | **CA17 - Extruder Pck. / Additive Handling Line 1+2** | 2012-02-20 | 2012-02-27 |
| 00 | **CA17 - General** |  |  |
| 0B | **General Activities** |  |  |
| C | **Civil Work** |  |  |
| R | **Piping** |  |  |
| E | **Electrical** |  |  |
| J | **Instrumentation** |  |  |
| 01 | **CA17 - Auxiliary/Monorail/Crane Structures** |  |  |
| 04 | **CA17 - Internal Pipe Racks** |  |  |
| C | **Civil Work** |  |  |
| N | **Structural Steel** |  |  |
| H | **HVAC** |  |  |
| U | **Package Units** |  |  |
| B | **Mechanical - Stationary Equipment** |  |  |
| M | **Mechanical - Rotating Equipment** |  |  |
| R | **Piping** |  |  |
| E | **Electrical** |  |  |
| J | **Instrumentation** |  |  |
| S | **Safety & Environment** |  |  |
| W | **Painting** |  |  |
| V | **Insulation** |  |  |
| 05 | **CA17 - Internal Platforms & Frames** |  |  |
| C | **Civil Work** |  |  |
| N | **Structural Steel** |  |  |
| H | **HVAC** |  |  |
| U | **Package Units** |  |  |
| B | **Mechanical - Stationary Equipment** |  |  |
| M | **Mechanical - Rotating Equipment** |  |  |
| R | **Piping** |  |  |
| E | **Electrical** |  |  |
| J | **Instrumentation** |  |  |
| S | **Safety & Environment** |  |  |
| W | **Painting** |  |  |
| V | **Insulation** |  |  |

| ID | WBS | Activity | Duration | Start | Finish | Predecessors | Total float | Free float | Constraint | Calendar |
| --- | --- | --- | --- | --- | --- | --- | --- | --- | --- | --- |
|  | 06 | **CA17 - Cladding Support Structure & Cladding** |  |  |  |  |  |  |  |  |
|  | C | **Civil Work** |  |  |  |  |  |  |  |  |
|  | N | **Structural Steel** |  |  |  |  |  |  |  |  |
|  | H | **HVAC** |  |  |  |  |  |  |  |  |
|  | U | **Package Units** |  |  |  |  |  |  |  |  |
|  | B | **Mechanical - Stationary Equipment** |  |  |  |  |  |  |  |  |
|  | M | **Mechanical - Rotating Equipment** |  |  |  |  |  |  |  |  |
|  | R | **Piping** |  |  |  |  |  |  |  |  |
|  | E | **Electrical** |  |  |  |  |  |  |  |  |
|  | J | **Instrumentation** |  |  |  |  |  |  |  |  |
|  | S | **Safety & Environment** |  |  |  |  |  |  |  |  |
|  | W | **Painting** |  |  |  |  |  |  |  |  |
|  | V | **Insulation** |  |  |  |  |  |  |  |  |
|  | 07 | **CA17 - Connection Piperack - CA17 to CA51/CA12** |  |  |  |  |  |  |  |  |
|  | C | **Civil Work** |  |  |  |  |  |  |  |  |
|  | N | **Structural Steel** |  |  |  |  |  |  |  |  |
|  | H | **HVAC** |  |  |  |  |  |  |  |  |
|  | U | **Package Units** |  |  |  |  |  |  |  |  |
|  | B | **Mechanical - Stationary Equipment** |  |  |  |  |  |  |  |  |
|  | M | **Mechanical - Rotating Equipment** |  |  |  |  |  |  |  |  |
|  | R | **Piping** |  |  |  |  |  |  |  |  |
|  | E | **Electrical** |  |  |  |  |  |  |  |  |
|  | J | **Instrumentation** |  |  |  |  |  |  |  |  |
|  | S | **Safety & Environment** |  |  |  |  |  |  |  |  |
|  | W | **Painting** |  |  |  |  |  |  |  |  |
|  | V | **Insulation** |  |  |  |  |  |  |  |  |
|  | 08 | **CA17 - Connection Piperack - CA17 to CA51/CA13** |  |  |  |  |  |  |  |  |
|  | C | **Civil Work** |  |  |  |  |  |  |  |  |
|  | N | **Structural Steel** |  |  |  |  |  |  |  |  |
|  | H | **HVAC** |  |  |  |  |  |  |  |  |
|  | U | **Package Units** |  |  |  |  |  |  |  |  |
|  | B | **Mechanical - Stationary Equipment** |  |  |  |  |  |  |  |  |
|  | M | **Mechanical - Rotating Equipment** |  |  |  |  |  |  |  |  |
|  | R | **Piping** |  |  |  |  |  |  |  |  |
|  | E | **Electrical** |  |  |  |  |  |  |  |  |
|  | J | **Instrumentation** |  |  |  |  |  |  |  |  |
|  | S | **Safety & Environment** |  |  |  |  |  |  |  |  |
|  | W | **Painting** |  |  |  |  |  |  |  |  |
|  | V | **Insulation** |  |  |  |  |  |  |  |  |
|  | 10 | **CA17 - Extrusion Bldg 1st Floor +0,15m** |  | 2012-02-20 | 2012-02-27 |  |  |  |  |  |
|  | C | **Civil Work** |  |  |  |  |  |  |  |  |
|  | N | **Structural Steel** |  |  |  |  |  |  |  |  |
|  | H | **HVAC** |  |  |  |  |  |  |  |  |
|  | U | **Package Units** |  |  |  |  |  |  |  |  |
|  | B | **Mechanical - Stationary Equipment** |  |  |  |  |  |  |  |  |
|  | M | **Mechanical - Rotating Equipment** |  |  |  |  |  |  |  |  |
|  | R | **Piping** |  |  |  |  |  |  |  |  |
|  | E | **Electrical** |  |  |  |  |  |  |  |  |
|  | J | **Instrumentation** |  | 2012-02-20 | 2012-02-27 |  |  |  |  |  |
| XJ8017115 |  | CA17 ExtrBldgFl1 - SAT System/ IC/ PD Cabinets | 7d | 2012-02-20 | 2012-02-27 | XJ201710 (other project) | -42d | 65d | start on 2012-01-09 | TB26 - 3 - Construction Normal 7days * CA17 |

| WBS | Activity |
| --- | --- |
| S | **Safety & Environment** |
| W | **Painting** |
| V | **Insulation** |
| 11 | **CA17 - Extrusion Structure** |
| 18 | **CA17 - Extrusion Bldg 2nd Floor +12,75m** |
| C | **Civil Work** |
| N | **Structural Steel** |
| H | **HVAC** |
| U | **Package Units** |
| B | **Mechanical - Stationary Equipment** |
| M | **Mechanical - Rotating Equipment** |
| R | **Piping** |
| E | **Electrical** |
| J | **Instrumentation** |
| W | **Painting** |
| V | **Insulation** |
| 20 | **CA17 - Extrusion Bldg 3rd Floor +19,05m** |
| C | **Civil Work** |
| N | **Structural Steel** |
| H | **HVAC** |
| U | **Package Units** |
| B | **Mechanical - Stationary Equipment** |
| M | **Mechanical - Rotating Equipment** |
| R | **Piping** |
| E | **Electrical** |
| J | **Instrumentation** |
| W | **Painting** |
| V | **Insulation** |
| 30 | **CA17 - Extrusion Bldg 4th Floor +25,35m** |
| C | **Civil Work** |
| N | **Structural Steel** |
| H | **HVAC** |
| U | **Package Units** |
| B | **Mechanical - Stationary Equipment** |
| M | **Mechanical - Rotating Equipment** |
| R | **Piping** |
| E | **Electrical** |
| J | **Instrumentation** |
| W | **Painting** |
| V | **Insulation** |
| 36 | **CA17 - Extrusion Bldg 5th Floor +31,65m** |
| C | **Civil Work** |
| N | **Structural Steel** |
| H | **HVAC** |
| U | **Package Units** |
| B | **Mechanical - Stationary Equipment** |
| M | **Mechanical - Rotating Equipment** |
| R | **Piping** |
| E | **Electrical** |
| J | **Instrumentation** |
| W | **Painting** |
| V | **Insulation** |
| 40 | **CA17 - Extrusion Bldg 6th Floor +37,95m** |
| C | **Civil Work** |
| N | **Structural Steel** |
| H | **HVAC** |
| U | **Package Units** |
| B | **Mechanical - Stationary Equipment** |
| M | **Mechanical - Rotating Equipment** |
| R | **Piping** |
| E | **Electrical** |
| J | **Instrumentation** |
| W | **Painting** |
| V | **Insulation** |
| 60 | **CA17 - Purge Bin Structure +94m** |
| 0B | **General Activities** |
| C | **Civil Work** |
| N | **Structural Steel** |
| H | **HVAC** |
| U | **Package Units** |

| ID | WBS | Activity | Duration | Start | Finish | Predecessors | Total float | Free float | Constraint |
| --- | --- | --- | --- | --- | --- | --- | --- | --- | --- |
|  | B | **Mechanical - Stationary Equipment** |  |  |  |  |  |  |  |
|  | M | **Mechanical - Rotating Equipment** |  |  |  |  |  |  |  |
|  | R | **Piping** |  |  |  |  |  |  |  |
|  | E | **Electrical** |  |  |  |  |  |  |  |
|  | J | **Instrumentation** |  |  |  |  |  |  |  |
|  | W | **Painting** |  |  |  |  |  |  |  |
|  | V | **Insulation** |  |  |  |  |  |  |  |
|  | 70 | **CA17 - Entrance Hall southside** |  |  |  |  |  |  |  |
|  | C | **Civil Work** |  |  |  |  |  |  |  |
|  | N | **Structural Steel** |  |  |  |  |  |  |  |
|  | H | **HVAC** |  |  |  |  |  |  |  |
|  | 18 | **CA18 - Chiller Unit** |  |  |  |  |  |  |  |
|  | 00.0B | **CA18 - General** |  |  |  |  |  |  |  |
|  | 31 | **CA31 - Blenders & Storage Silos / Packaging & Shipping** |  | 2012-04-09 | 2012-08-29 |  |  |  |  |
|  | 00 | **CA31 - General** |  |  |  |  |  |  |  |
|  | 0B | **General Activities** |  |  |  |  |  |  |  |
|  | C | **Civil Work** |  |  |  |  |  |  |  |
|  | 04 | **CA31 - Auxiliary Structures Zeppelin** |  |  |  |  |  |  |  |
|  | 10 | **CA31(3101) - Silo Structure** |  |  |  |  |  |  |  |
|  | C | **Civil Work** |  |  |  |  |  |  |  |
|  | N | **Structural Steel** |  |  |  |  |  |  |  |
|  | H | **HVAC** |  |  |  |  |  |  |  |
|  | U | **Package Units** |  |  |  |  |  |  |  |
|  | B | **Mechanical - Stationary Equipment** |  |  |  |  |  |  |  |
|  | M | **Mechanical - Rotating Equipment** |  |  |  |  |  |  |  |
|  | R | **Piping** |  |  |  |  |  |  |  |
|  | E | **Electrical** |  |  |  |  |  |  |  |
|  | J | **Instrumentation** |  |  |  |  |  |  |  |
|  | S | **Safety & Environment** |  |  |  |  |  |  |  |
|  | W | **Painting** |  |  |  |  |  |  |  |
|  | V | **Insulation** |  |  |  |  |  |  |  |
|  | 15 | **CA31(3105) - Conveying Tower** |  |  |  |  |  |  |  |
|  | 20 | **CA31(3103) - Blower Room & Truck Inliner Loading** |  |  |  |  |  |  |  |
|  | C | **Civil Work** |  |  |  |  |  |  |  |
|  | N | **Structural Steel** |  |  |  |  |  |  |  |
|  | H | **HVAC** |  |  |  |  |  |  |  |
|  | U | **Package Units** |  |  |  |  |  |  |  |
|  | B | **Mechanical - Stationary Equipment** |  |  |  |  |  |  |  |
|  | M | **Mechanical - Rotating Equipment** |  |  |  |  |  |  |  |
|  | R | **Piping** |  |  |  |  |  |  |  |
|  | E | **Electrical** |  |  |  |  |  |  |  |
|  | J | **Instrumentation** |  |  |  |  |  |  |  |
|  | S | **Safety & Environment** |  |  |  |  |  |  |  |
|  | W | **Painting** |  |  |  |  |  |  |  |
|  | V | **Insulation** |  |  |  |  |  |  |  |
|  | 30 | **CA31(3104) - Service Area** |  | 2012-04-09 | 2012-04-16 |  |  |  |  |
|  | 0B | **General Activities** |  |  |  |  |  |  |  |
|  | C | **Civil Work** |  |  |  |  |  |  |  |
|  | N | **Structural Steel** |  |  |  |  |  |  |  |
|  | H | **HVAC** |  |  |  |  |  |  |  |
|  | U | **Package Units** |  |  |  |  |  |  |  |
|  | B | **Mechanical - Stationary Equipment** |  |  |  |  |  |  |  |
|  | M | **Mechanical - Rotating Equipment** |  |  |  |  |  |  |  |
|  | R | **Piping** |  |  |  |  |  |  |  |
|  | E | **Electrical** |  |  |  |  |  |  |  |
|  | J | **Instrumentation** |  | 2012-04-09 | 2012-04-16 |  |  |  |  |
| XJ2031305 |  | CA31 Service Area - SAT System/ IC/ PD cabs | 7d | 2012-04-09 | 2012-04-16 | XJ203130 (other project) | -87d | 58d | start on 2011-12-20 |

| ID | WBS | Activity | Duration | Start | Finish | Predecessors | Total float | Free float | Constraint |
| --- | --- | --- | --- | --- | --- | --- | --- | --- | --- |
|  | S | **Safety & Environment** |  |  |  |  |  |  |  |
|  | W | **Painting** |  |  |  |  |  |  |  |
|  | V | **Insulation** |  |  |  |  |  |  |  |
|  | 40 | **CA31 (3102)- Warehouse** |  | 2012-07-03 | 2012-08-29 |  |  |  |  |
|  | C | **Civil Work** |  |  |  |  |  |  |  |
|  | N | **Structural Steel** |  |  |  |  |  |  |  |
|  | H | **HVAC** |  |  |  |  |  |  |  |
|  | U | **Package Units** |  |  |  |  |  |  |  |
|  | B | **Mechanical - Stationary Equipment** |  |  |  |  |  |  |  |
|  | M | **Mechanical - Rotating Equipment** |  |  |  |  |  |  |  |
|  | R | **Piping** |  |  |  |  |  |  |  |
|  | E | **Electrical** |  |  |  |  |  |  |  |
|  | J | **Instrumentation** |  | 2012-07-03 | 2012-08-29 |  |  |  |  |
| XJ803130 |  | CA31 Service Area - Inspections/ Mech. Acceptance/ Loop Checks | 50d | 2012-07-03 | 2012-08-29 | XJ2031305 (other project), X030410030 (other project), X3J120 (other project), XJ800C00 (other project) SS, XE500C00 (other project), XE50313020 (other project), XJ613130 (other project), XJ523130 (other project), XE503130 (other project), XE703130 (other project), XJ513130 (other project), XE203130 (other project), XJ2031305 (other project) FF | -26d | 0d | start on 2012-06-01 |
|  | S | **Safety & Environment** |  |  |  |  |  |  |  |
|  | W | **Painting** |  |  |  |  |  |  |  |
|  | V | **Insulation** |  |  |  |  |  |  |  |
|  | 32 | **CA32 - Container Yard** |  |  |  |  |  |  |  |
|  | 41 | **CA41 - Control Building** |  | 2012-04-28 | 2012-05-24 |  |  |  |  |
|  | 0B | **General Activities** |  |  |  |  |  |  |  |
|  | E | **Electrical** |  | 2012-04-28 | 2012-05-24 |  |  |  |  |
| XJ604100 |  | CA41 Control Bldg - SAT System + Systeminterconnection to CA16 | 21d | 2012-04-28 | 2012-05-24 | XE604100 (other project) | -62d | 0d | start on 2012-02-14 |
|  | J | **Instrumentation** |  |  |  |  |  |  |  |
|  | 51 | **CA51 - Pipe Rack** |  |  |  |  |  |  |  |
|  | 01 | **CA5101** |  |  |  |  |  |  |  |
|  | C | **Civil Work** |  |  |  |  |  |  |  |
|  | N | **Structural Steel** |  |  |  |  |  |  |  |
|  | H | **HVAC** |  |  |  |  |  |  |  |
|  | U | **Package Units** |  |  |  |  |  |  |  |
|  | B | **Mechanical - Stationary Equipment** |  |  |  |  |  |  |  |
|  | M | **Mechanical - Rotating Equipment** |  |  |  |  |  |  |  |
|  | R | **Piping** |  |  |  |  |  |  |  |
|  | E | **Electrical** |  |  |  |  |  |  |  |
|  | J | **Instrumentation** |  |  |  |  |  |  |  |
|  | S | **Safety & Environment** |  |  |  |  |  |  |  |
|  | W | **Painting** |  |  |  |  |  |  |  |
|  | V | **Insulation** |  |  |  |  |  |  |  |
|  | 02 | **CA5102** |  |  |  |  |  |  |  |
|  | C | **Civil Work** |  |  |  |  |  |  |  |
|  | N | **Structural Steel** |  |  |  |  |  |  |  |
|  | R | **Piping** |  |  |  |  |  |  |  |
|  | E | **Electrical** |  |  |  |  |  |  |  |
|  | J | **Instrumentation** |  |  |  |  |  |  |  |
|  | W | **Painting** |  |  |  |  |  |  |  |
|  | V | **Insulation** |  |  |  |  |  |  |  |
|  | 03 | **CA5103** |  |  |  |  |  |  |  |
|  | C | **Civil Work** |  |  |  |  |  |  |  |
|  | N | **Structural Steel** |  |  |  |  |  |  |  |
|  | R | **Piping** |  |  |  |  |  |  |  |
|  | E | **Electrical** |  |  |  |  |  |  |  |
|  | J | **Instrumentation** |  |  |  |  |  |  |  |
|  | W | **Painting** |  |  |  |  |  |  |  |
|  | V | **Insulation** |  |  |  |  |  |  |  |
|  | 04 | **CA5104** |  |  |  |  |  |  |  |
|  | C | **Civil Work** |  |  |  |  |  |  |  |
|  | N | **Structural Steel** |  |  |  |  |  |  |  |
|  | R | **Piping** |  |  |  |  |  |  |  |
|  | E | **Electrical** |  |  |  |  |  |  |  |
|  | J | **Instrumentation** |  |  |  |  |  |  |  |
|  | W | **Painting** |  |  |  |  |  |  |  |
|  | V | **Insulation** |  |  |  |  |  |  |  |
|  | 52 | **CA52 - Pipe Rack** |  |  |  |  |  |  |  |
|  | C | **Civil Work** |  |  |  |  |  |  |  |
|  | N | **Structural Steel** |  |  |  |  |  |  |  |
|  | H | **HVAC** |  |  |  |  |  |  |  |
|  | U | **Package Units** |  |  |  |  |  |  |  |
|  | B | **Mechanical - Stationary Equipment** |  |  |  |  |  |  |  |
|  | M | **Mechanical - Rotating Equipment** |  |  |  |  |  |  |  |
|  | R | **Piping** |  |  |  |  |  |  |  |
|  | E | **Electrical** |  |  |  |  |  |  |  |

| WBS | Activity |
| --- | --- |
| J | **Instrumentation** |
| S | **Safety & Environment** |
| W | **Painting** |
| V | **Insulation** |
| 53 | **CA53 - Pipe Rack** |
| 0B | **General Activities** |
| 01 | **CA5301** |
| C | **Civil Work** |
| N | **Structural Steel** |
| H | **HVAC** |
| U | **Package Units** |
| B | **Mechanical - Stationary Equipment** |
| M | **Mechanical - Rotating Equipment** |
| R | **Piping** |
| E | **Electrical** |
| J | **Instrumentation** |
| S | **Safety & Environment** |
| W | **Painting** |
| V | **Insulation** |
| 54 | **CA54 - Pipe Rack** |
| 0B | **General Activities** |
| 01 | **CA5401** |
| C | **Civil Work** |
| N | **Structural Steel** |
| H | **HVAC** |
| U | **Package Units** |
| B | **Mechanical - Stationary Equipment** |
| M | **Mechanical - Rotating Equipment** |
| R | **Piping** |
| E | **Electrical** |
| J | **Instrumentation** |
| S | **Safety & Environment** |
| W | **Painting** |
| V | **Insulation** |
| 02 | **CA5402** |
| C | **Civil Work** |
| N | **Structural Steel** |
| R | **Piping** |
| E | **Electrical** |
| J | **Instrumentation** |
| W | **Painting** |
| V | **Insulation** |
| 55 | **CA55 - Pipe Rack** |
| 0B | **General Activities** |
| 01 | **CA5501** |
| C | **Civil Work** |
| N | **Structural Steel** |
| H | **HVAC** |
| U | **Package Units** |
| B | **Mechanical - Stationary Equipment** |
| M | **Mechanical - Rotating Equipment** |
| R | **Piping** |
| E | **Electrical** |
| J | **Instrumentation** |
| S | **Safety & Environment** |
| W | **Painting** |
| V | **Insulation** |
| 02 | **CA5502** |
| C | **Civil Work** |
| N | **Structural Steel** |
| H | **HVAC** |
| U | **Package Units** |
| B | **Mechanical - Stationary Equipment** |
| M | **Mechanical - Rotating Equipment** |
| R | **Piping** |
| E | **Electrical** |
| J | **Instrumentation** |
| S | **Safety & Environment** |
| W | **Painting** |
| V | **Insulation** |

| WBS | Activity |
| --- | --- |
| 03 | **CA5503** |
| C | **Civil Work** |
| N | **Structural Steel** |
| H | **HVAC** |
| U | **Package Units** |
| B | **Mechanical - Stationary Equipment** |
| M | **Mechanical - Rotating Equipment** |
| R | **Piping** |
| E | **Electrical** |
| J | **Instrumentation** |
| S | **Safety & Environment** |
| W | **Painting** |
| V | **Insulation** |
| 56 | **CA56 - Pipe Rack** |
| 0B | **General Activities** |
| C | **Civil Work** |
| N | **Structural Steel** |
| H | **HVAC** |
| U | **Package Units** |
| B | **Mechanical - Stationary Equipment** |
| M | **Mechanical - Rotating Equipment** |
| R | **Piping** |
| E | **Electrical** |
| J | **Instrumentation** |
| S | **Safety & Environment** |
| W | **Painting** |
| V | **Insulation** |
| 90 | **CA90 - Underground Piping** |
| 96 | **CA96 - Roads / Paving** |
| 98 | **CA98 - Miscellaneous** |
| 99 | **CA99 - Existing** |
| OV | **Overall** |
| Y | **Precommissioning** |
| 0Y | **0Y Precommissioning** |
| 0000 | **0000 Generals - all CA's** |
| 0B | **0B General Activities** |
| Y | **Y Precommissioning** |
| Z | **Commissioning** |
| 0Z | **0Z Commissioning** |
| 0000 | **0000 Generals - all CA's** |
| I | **I Ineos Activities** |
| S | **Start-Up** |
| 0Z | **0Z Commissioning** |
| 0000 | **0000 Generals - all CA's** |
| 0B | **0B General Activities** |
| I | **I Ineos Activities** |
| T | **Template per Discipline** |
| 0B | **General Activities** |
| C | **Civil Work** |
| N | **Structural Steel** |
| H | **HVAC** |
| U | **Package Units** |
| B | **Mechanical - Stationary Equipment** |
| M | **Mechanical - Rotating Equipment** |
| R | **Piping** |
| E | **Electrical** |
| J | **Instrumentation** |
| S | **Safety & Environment** |
| W | **Painting** |
| V | **Insulation** |
